# October 13 Progress 12 GeV CR13-015,14-001

Schedule from Primavera P6, 2004-03-31 to 2017-12-19, data date 2013-10-31, costs in USD, A marks actual dates.
CHANGE REQUESTS INCLUDED / FY07 002, 003, 006, 007, 008, 010, 005, 009, 014, 012, 15, / 17, 18, 29-33 / FY08 / 001,002,003,005,004,011,014,013,009,016,018,017,019,020,24N/C,23,10,25,21,22,27,28,26,31,29,32,33,34,35, / 36,37,38,39,40,41,42,44,43,45,46,48,49,51,50,52,54,55,56, 57 ,58,59,60 / FY09 003, 002, 004, 005, 007, 008, 009, 010, 011, 012, / 14A-G,16,17,15,23, / 26,22,24,31,35,34,33,32,27,28,36,30,37,38,43,40,46,41,47,48,44,43A,49,52,51,39,42,53,64,66,61,71,70,67,63,01VA / FY10 001A-E,002, 005 ,003,004, / 008,007,010,011,012,18,23,12A,035,036,22,32,33,34,20,21,29,37,24,26,9,19,30,27,41,38,40,43,39,44,16,45,25,28,31, / 14,46,48,52,53,54,56,55,42,57,47,17,15,62,59,64,66,61,71,70,67,63,VA1,60,65,73 / FY11 / 001,002,007,003,010,016,011,014,15,19,09,17,18,12,13,20,06,08,22,23,VA2,VA3,26,24,27,31,28,30,29,38,25,32,37,46,47,35,40,43,42,44,41,22a,49,52,51,005,48,39,36,55,57,54,53 / FY12 001-A&D, / 005,002,003,007,010,009,011,008,012,014,015,016,17,13,22,25,18,23,21,26,24,29,28,27,29A,34,37,38,35,36,32,39,42,44,45,43,50,46,47,53,51,54,49,55 / FY13 001D,003,008,009,002,004,005,12,06,11,14,15,16 / This project is to be used to develop the new DOE guidance schedule / Mark Wiseman's PED corrections have been made - RKC / Implemented IPLs with 6 GeV / Hardening Schedule- 27 August 08 PMK
Must finish by 2017-09-30

## Calendars

- 8/5 M-F w/JLAB Holidays STANDARD: Mon-Fri 08:00-16:00; Sat-Sun off. Exceptions (off unless hours are given): 2004-05-31, 2004-07-05, 2004-09-06, 2004-11-25 to 2004-11-26, 2004-12-24, 2004-12-27 to 2004-12-31, 2005-01-17, 2005-02-14, 2005-05-30, 2005-07-04, 2005-09-05, 2005-11-24 to 2005-11-25, 2005-12-26 to 2005-12-30, 2006-01-02, 2006-01-16, 2006-02-20, 2006-05-29, 2006-07-04, 2006-09-04, 2006-11-23 to 2006-11-24, 2006-12-25 to 2006-12-29, 2007-01-01, 2007-01-15, 2007-02-19, 2007-05-28, 2007-07-04, 2007-09-03, 2007-11-22 to 2007-11-23, 2007-12-24 to 2007-12-28, 2007-12-31 to 2008-01-01, 2008-01-21, 2008-02-18, 2008-05-26, 2008-07-04, 2008-09-01, 2008-11-27 to 2008-11-28, 2008-12-25 to 2008-12-26, 2008-12-29 to 2009-01-01, 2009-01-19, 2009-02-16, 2009-05-25, 2009-07-03, 2009-09-07, 2009-11-26 to 2009-11-27, 2009-12-21 to 2009-12-25, 2010-01-01, 2010-01-18, 2010-02-15, 2010-05-31, 2010-07-05, 2010-09-06, 2010-11-25 to 2010-11-26, 2010-12-22 to 2010-12-24, 2010-12-27 to 2010-12-28, 2011-01-03, 2011-01-17, 2011-02-21, 2011-05-30, 2011-07-04, 2011-09-05, 2011-11-24 to 2011-11-25, 2011-12-22 to 2011-12-23, 2011-12-26 to 2011-12-28, 2012-01-02, 2012-01-16, 2012-02-20, 2012-05-28, 2012-06-04, 2012-09-03, 2012-11-22 to 2012-11-23, 2012-12-24 to 2012-12-28, 2013-01-01, 2013-01-21, 2013-02-18, 2013-05-27, 2013-07-04, 2013-09-02, 2013-11-28 to 2013-11-29, 2013-12-23 to 2013-12-27, 2014-01-01, 2014-01-20, 2014-02-17, 2014-05-26, 2014-07-04, 2014-09-01, 2014-11-27 to 2014-11-28, 2014-12-22 to 2014-12-26, 2015-01-01, 2015-01-20, 2015-02-24, 2015-06-01, 2015-07-03, 2015-07-06, 2015-09-07, 2015-11-26 to 2015-11-27, 2015-12-24 to 2015-12-25, 2015-12-28 to 2016-01-01, 2016-01-18, 2016-02-15, 2016-05-30, 2016-07-04, 2016-09-05, 2016-11-24 to 2016-11-25, 2016-12-26 to 2016-12-30, 2017-01-02, 2017-01-16, 2017-02-20, 2017-05-29, 2017-07-04, 2017-09-04, 2017-11-23 to 2017-11-24.
- 8/5 M-F w/JLAB Holidays ReBaseline: Mon-Fri 08:00-16:00; Sat-Sun off. Exceptions (off unless hours are given): 2004-05-31, 2004-07-05, 2004-09-06, 2004-11-25 to 2004-11-26, 2004-12-24, 2004-12-27 to 2004-12-31, 2005-01-17, 2005-02-14, 2005-05-30, 2005-07-04, 2005-09-05, 2005-11-24 to 2005-11-25, 2005-12-26 to 2005-12-30, 2006-01-02, 2006-01-16, 2006-02-20, 2006-05-29, 2006-07-04, 2006-09-04, 2006-11-23 to 2006-11-24, 2006-12-25 to 2006-12-29, 2007-01-01, 2007-01-15, 2007-02-19, 2007-05-28, 2007-07-04, 2007-09-03, 2007-11-22 to 2007-11-23, 2007-12-24 to 2007-12-28, 2007-12-31 to 2008-01-01, 2008-01-21, 2008-02-18, 2008-05-26, 2008-07-04, 2008-09-01, 2008-11-27 to 2008-11-28, 2008-12-25 to 2008-12-26, 2008-12-29 to 2009-01-01, 2009-01-19, 2009-02-16, 2009-05-25, 2009-07-03, 2009-09-07, 2009-11-26 to 2009-11-27, 2009-12-21 to 2009-12-25, 2010-01-01, 2010-01-18, 2010-02-15, 2010-05-31, 2010-07-05, 2010-09-06, 2010-11-25 to 2010-11-26, 2010-12-22 to 2010-12-24, 2010-12-27 to 2010-12-28, 2011-01-03, 2011-01-17, 2011-02-21, 2011-05-30, 2011-07-04, 2011-09-05, 2011-11-24 to 2011-11-25, 2011-12-22 to 2011-12-23, 2011-12-26 to 2011-12-28, 2012-01-02, 2012-01-16, 2012-02-20, 2012-05-28, 2012-06-04, 2012-09-03, 2012-11-22 to 2012-11-23, 2012-12-24 to 2012-12-28, 2013-01-01, 2013-01-21, 2013-02-18, 2013-05-27, 2013-07-04, 2013-09-02, 2013-11-28 to 2013-11-29, 2013-12-23 to 2013-12-27, 2013-12-30 to 2014-01-01, 2014-01-20, 2014-05-26, 2014-07-04, 2014-09-01, 2014-11-27 to 2014-11-28, 2014-12-24 to 2014-12-26, 2014-12-29 to 2015-01-02, 2015-01-19, 2015-05-25, 2015-06-01, 2015-07-03, 2015-09-07, 2015-11-26 to 2015-11-27, 2015-12-24 to 2015-12-25, 2015-12-28 to 2016-01-01, 2016-01-18, 2016-05-30, 2016-07-04, 2016-09-05, 2016-11-24 to 2016-11-25, 2016-12-23, 2016-12-26 to 2016-12-30, 2017-01-02, 2017-01-16, 2017-05-29, 2017-07-04, 2017-09-04, 2017-11-23 to 2017-11-24.

## Resources

| Resource | Group | Unit | Rate | Notes |
| --- | --- | --- | --- | --- |
| MECH TECH | labor |  | 47.32 |  |
| MECH DES | labor |  | 51.3 |  |
| PROCUREMENT<$50K 60 | material | unit |  |  |
| PROCUREMENT>$50K 69 NO ESCALATION | material | unit |  |  |
| PD UNIV STUDNT | labor |  | 11.36 |  |
| SCIENTIST | labor |  | 75.18 |  |
| SKLLD TRADE | labor |  | 35.62 |  |
| ELEC TECH | labor |  | 46.99 |  |
| PD UNIV STAFF | labor |  | 59.83 |  |
| TRAVEL | equipment |  |  |  |
| SUPPLIES & MATERIALS | equipment |  |  |  |
| VISTNG USERS | labor |  | 20.59 |  |
| COMP SCIENT | labor |  | 69.87 |  |
| PLABOR | equipment |  |  |  |
| MECH ENG | labor |  | 74.67 |  |
| PROCUREMENT>$50K 69 | material | unit |  |  |
| PROCUREMENT>$50K 69 NO ESCALATION FY15 | material | unit |  |  |
| SR STAFF | labor |  | 120.32 | Robert Rimmer, / Larry Phillips, / Charlie Reece, / Joe Preble, / Peter Kneisel, / Jacek Sekutowicz / (1/2) |
| PROCUREMENT<$50K 60 NO ESCALATION FY14 | material | unit |  |  |
| ELEC ENG | labor |  | 75.13 |  |
| PROCUREMENT<$50K 60 NO ESCALATION | material | unit |  |  |
| MSHOP | equipment |  |  |  |
| PROCUREMENT>$50K 69 NO ESCALATION FY14 | material | unit |  |  |
| PROCUREMENT<$50K 60 NO ESCALATION FY15 | material | unit |  |  |
| PLABOR | equipment |  |  |  |
| ELEC DES | labor |  | 53.78 |  |
| OFFICE | labor |  | 30.4 | Carolyn Camp |
| PROCUREMENT<$50K 60 NO ESCALATION FY13 | material | unit |  |  |
| PROCUREMENT>$50K 69 NO ESCALATION FY13 | material | unit |  |  |
| CONTRB UNIV LBR | labor |  |  |  |
| PLANT ENG | labor |  | 74.79 |  |
| PROCUREMENT<$50K 60 NO ESCALATION FY12 | material | unit |  |  |
| PLABOR | equipment |  |  |  |
| PLABOR | equipment |  |  |  |
| PROCUREMENT<$50K 60 NO ESCALATION FY11 | material | unit |  |  |
| PROCUREMENT>$50K 69 NO ESCALATION FY11 | material | unit |  |  |
| PROCUREMENT<$50K 60 NO ESCALATION FY10 | material | unit |  |  |
| PROCUREMENT>$50K 69 NO ESCALATION FY10 | material | unit |  |  |
| PROCUREMENT>$50K 69 NO ESCALATION FY12 | material | unit |  |  |
| PLABOR | equipment |  |  |  |
| MECH ENG | labor |  | 72.36 |  |
| EXPENSES >$50 69 | equipment |  |  |  |
| PLABOR | equipment |  |  |  |
| PROCUREMENT<$50K 60 NO ESCALATION FY08 | material | unit |  |  |
| ADMIN | labor |  | 62.54 |  |
| DIRECTORATE | labor |  | 203.37 |  |
| MECH ENG | labor |  | 72.36 |  |
| MECH DES | labor |  | 49.71 | Larry Turlington |
| MECH ENG | labor |  | 72.36 | Brian Carpenter |
| MECH ENG | labor |  | 72.36 |  |
| MECH ENG | labor |  | 72.36 |  |
| ELEC TECH | labor |  | 45.54 | Will Sommer, / Danny Forehand, / Jim Gordon, / Roland / Overton |
| MECH ENG | labor |  | 72.36 | Steve / Manning, / Rich Bundy |
| MECH TECH | labor |  | 45.86 | Jeff / Campbell, / Mike McC rea, / Ken Worland, / Leonard Page, / Scott Williams, / Steven / Castagnola, / Chris Dreyfus |
| ELEC TECH | labor |  | 45.54 | Thomas Goodman, / Henry Whitehead, / Derek / Dale, / Steve / Dutton, / Larry King |
| ELEC ENG | labor |  | 72.81 | Kirk Davis, / Mike Drury |
| SCIENTIST | labor |  | 72.86 | Haipeng Wang, / Mircea Stirbet, / Frank Marhauser |
| MECH DES | labor |  | 49.71 |  |
| MECH ENG | labor |  | 72.36 | Jeffrey Saunders |
| MECH TECH | labor |  | 45.86 |  |
| MECH TECH | labor |  | 45.86 | Frank Humphry, / Dave Bigelow, / Scott / Williams |
| MECH TECH | labor |  | 45.86 | James Davenport / , / George Dekerlegand, / Bryon Golden, / Tina / Harris, / Isiah / Daniels |
| PROCUREMENT<$50K 60 NO ESCALATION FY09 | material | unit |  |  |
| PROCUREMENT>$50K 69 NO ESCALATION FY09 | material | unit |  |  |
| PLABOR | equipment |  |  |  |
| SCIENTIST | labor |  | 72.86 |  |
| PROCUREMENT>$50K 69 NO ESCALATION FY08 | material | unit |  |  |
| SCIENTIST | labor |  | 72.86 |  |
| MECH DES | labor |  | 49.71 |  |

## Schedule

| ID | WBS | Activity | Type | Duration | Start | Finish | Predecessors | Complete | Planned start | Planned finish | Total float | Free float | Constraint | Calendar | Planned FinishUDF | MONTHLY EV COST | GROP Group | RESP - Responsibility | MILE - Milestone | STRT%COMP for CM EVM | FNSH%COMP for CM EVM | Milestone Level | EVMS Reporting Codes | CAM RESPONSIBLE | PPEP Date | 12 GeV 1st level Critical Path | CIVIL CRITICAL MILESTONES | Profile change | 12 GeV 5th level Critical Path | Post Rebaseline | CR 09-023 | CR 10-028 | CR 10-064 | CR 10-066 | CR 11-015 | CR 12-018 | Inter Project Link (IPL) | CR 10-065 | CR 12-029 | CR 12-050 | CR 11-026 | CR 12-025 | CR 08-052 | CR 09-030 | CR 09-030 Repair | CR 09-028 | CR 08-048 | CR 09-022 | CR 09-041 | CR 10-067 | CR 10-069 | CR 11-046 | CR 12-003 | CR 12-012 | CR 12-036 | CR 10-063 | CR 10-074 | CR 11-017 | CR 11-025 | CR 11-035 | CR 12-024 | CR 13-002 | CR 10-008 | CR 10-076 | SC Magnet Dates | CR 12-054 | Original Activity ID Rebaseline | CR 09-028 Repair | CR 13-006 | CR 13-010 |
| --- | --- | --- | --- | --- | --- | --- | --- | --- | --- | --- | --- | --- | --- | --- | --- | --- | --- | --- | --- | --- | --- | --- | --- | --- | --- | --- | --- | --- | --- | --- | --- | --- | --- | --- | --- | --- | --- | --- | --- | --- | --- | --- | --- | --- | --- | --- | --- | --- | --- | --- | --- | --- | --- | --- | --- | --- | --- | --- | --- | --- | --- | --- | --- | --- | --- | --- | --- | --- | --- | --- |
|  | 0M | **1.M MILESTONES** |  |  | 2004-03-31 | 2017-09-29 |  |  |  |  |  |  |  |  |  |  |  |  |  |  |  |  |  |  |  |  |  |  |  |  |  |  |  |  |  |  |  |  |  |  |  |  |  |  |  |  |  |  |  |  |  |  |  |  |  |  |  |  |  |  |  |  |  |  |  |  |  |  |  |  |
|  | 1.01M | **1.01 LEVEL 1 MILESTONES** |  |  | 2004-03-31 | 2017-09-29 |  |  |  |  |  |  |  |  |  |  |  |  |  |  |  |  |  |  |  |  |  |  |  |  |  |  |  |  |  |  |  |  |  |  |  |  |  |  |  |  |  |  |  |  |  |  |  |  |  |  |  |  |  |  |  |  |  |  |  |  |  |  |  |  |
| 1-1M |  | CD-0 (Approve Mission Need) | milestone | 0d | 2004-03-31 A | 2004-03-31 A |  | 100% |  |  |  |  |  |  | 2004-03-31 | 0 | CDS | DOE | 0 | 1 | 1 | 1 | N/A | CLAUS R |  |  |  |  |  |  |  |  |  |  |  |  |  |  |  |  |  |  |  |  |  |  |  |  |  |  |  |  |  |  |  |  |  |  |  |  |  |  |  |  |  |  |  |  |  |  |
| 1-2M |  | CD-1 (Approve Preliminary Baseline Range) | milestone | 0d | 2006-02-15 A | 2006-02-15 A | 1-1M FS+399d | 100% |  |  |  |  | finish on or after 2005-09-30 |  | 2006-02-15 | 0 | CDS | DOE | 0 | 1 | 1 | 1 | N/A | CLAUS R |  |  |  |  |  |  |  |  |  |  |  |  |  |  |  |  |  |  |  |  |  |  |  |  |  |  |  |  |  |  |  |  |  |  |  |  |  |  |  |  |  |  |  |  |  |  |
| 1-5M |  | CD-2 (Approve Performance Baseline) | milestone | 0d | 2007-11-09 A | 2007-11-09 A | 121224022, 1241056M, 121224030, 3R-3M, 1241096M, 121221055, 1241016M, 1241176M, 1241136M, 121223030 | 100% | 2008-01-02 | 2008-01-02 |  |  | mandatory finish 2007-12-28 |  | 2007-09-28 | 0 | CDS | DOE | 0 | 1 | 1 | 1 | N/A | CLAUS R |  |  |  |  |  |  |  |  |  |  |  |  |  |  |  |  |  |  |  |  |  |  |  |  |  |  |  |  |  |  |  |  |  |  |  |  |  |  |  |  |  |  |  |  |  |  |
| 1-6M |  | CD-3 (Approve Start of Constr) | milestone | 0d | 2008-09-15 A | 2008-09-15 A | 1142030, 1212112908LOE, 1152945LOE, 117908LOE, 3R-05M, 3R-08M, 122311908LOE, 1211005M5, 1212111908LOE | 100% | 2008-10-01 | 2008-10-01 |  |  | mandatory finish 2008-09-30 |  |  | 0 | CDS | DOE | 0 | 1 | 1 | 1 | M | CLAUS R | 2008-09-30 | 1 | CVL | C | 5 |  |  |  |  |  |  |  |  |  |  |  |  |  |  |  |  |  |  |  |  |  |  |  |  |  |  |  |  |  |  |  |  |  |  |  |  |  |  |  |  |  |
| 1-7M |  | CD-4A ( Approve Accelerator Completion & Start of Operations) | milestone | 0d | 2014-12-23 | 2014-12-23 | 2-S09M, 23224087a, 281315030a, 3A-59M, 2-S01M, 3C-13M, 2-S08M, 23641914LOE, 23221023Ga, 2-S11M, 2-S02M, 2-S05M, 2-S04M, 13421050M, 23221023Da, 2-S03M, 2-S06M, 2-S10M, 28000, 23642914LOE, 23643914LOE, 13422123b, 23221140LOEa, 23224087, 2-S07M, 281315030 |  |  |  | 0d |  | mandatory finish 2014-12-23 | 8/5 M-F w/JLAB Holidays ReBaseline |  | 0 |  | DOE |  | 1 | 1 | 1 | M | CLAUS R |  |  |  | C |  | PR |  |  |  |  |  |  |  |  |  |  |  |  |  |  |  |  |  |  |  |  |  |  |  |  |  |  |  |  |  |  |  |  |  |  |  |  |  |  |  |  |
| 1-8M |  | CD-4B (Approve Proj Compltn & Start of Operations) | milestone | 0d | 2017-09-29 | 2017-09-29 | 28020, 28010, 1-7M, 2-08M, 28025, 2-06M, 28005, 28015, 2831916LOE |  |  |  | 0d |  | mandatory finish 2017-09-29 | 8/5 M-F w/JLAB Holidays ReBaseline |  | 0 | CDS | DOE | 0 | 1 | 1 | 1 | M | CLAUS R |  | 1 |  | C |  | PR |  |  |  |  |  |  |  |  |  |  |  |  |  |  |  |  |  |  |  |  |  |  |  |  |  |  |  |  |  |  |  |  |  |  |  |  |  |  |  |  |
|  | 1.02A | **1.02A LEVEL 2 ACCELERATOR MILESTONES** |  |  | 2011-03-08 | 2014-06-25 |  |  |  |  |  |  |  |  |  |  |  |  |  |  |  |  |  |  |  |  |  |  |  |  |  |  |  |  |  |  |  |  |  |  |  |  |  |  |  |  |  |  |  |  |  |  |  |  |  |  |  |  |  |  |  |  |  |  |  |  |  |  |  |  |
| 2-01M |  | Klystron Mass Production Authorization | milestone | 0d | 2011-03-08 A | 2011-03-08 A | 132111049 FS+15d | 100% | 2011-04-01 | 2011-04-01 |  |  | start on or before 2011-06-30 |  |  | 0 |  | RODE C |  | 1 | 1 | 2 | M | CLAUS R |  |  |  |  |  |  | 09-023 | 10-028 | 10-064 | 10-066 | 11-015 | 12-018F |  |  |  |  |  |  |  |  |  |  |  |  |  |  |  |  |  |  |  |  |  |  |  |  |  |  |  |  |  |  |  |  |  |  |
| 2-02M |  | Start Accelerator Installation Shutdown (IPL) | milestone | 0d | 2012-05-18 A | 2012-05-18 A | 13416035M FS-80d, 13417015, 13444020, 13444015, 13433005, 13432015, 13435010, 13451100a, 13456045, 13456042, 13444025, 13421030a, 13411140a, 13451105a, 13454040 FS-60d, 13414095M FS-150d, 13414030M FS-175d, 13416049A, 13411070M, 13456022LOEa, 13414055, 13445005, 13446010b, 13454047, 13434005a, 13451095, 13421070M, 13411200a, 13456035, 1317015, 13416049B FS-50d, 13411196 FS-40d | 100% | 2012-06-01 | 2012-06-01 |  |  | mandatory start 2012-05-14 |  |  | 0 |  | RODE C |  | 1 | 1 | 2 | M | CLAUS R | 2010-12-31 |  |  |  |  |  |  |  |  |  |  |  | IPL |  |  |  |  |  |  |  |  |  |  |  |  |  |  |  |  |  |  |  |  |  |  |  |  |  |  |  |  |  |  |  |  |  |
| 2-26M |  | Accel Installtn Comptd Except for All Power Supplies | milestone | 0d | 2013-11-27 | 2013-11-27 | 4A-09M, 4A-08M, 4A-07M |  |  |  | 19d | 0d |  | 8/5 M-F w/JLAB Holidays ReBaseline |  | 0 | CVL | HARWOOD L | 4 | 1 | 1 | 3 | M | LEIGH H |  |  |  |  |  | PR |  |  |  |  |  | 12-018 |  | 10-065 | 12-029 | 12-050 |  |  |  |  |  |  |  |  |  |  |  |  |  |  |  |  |  |  |  |  |  |  |  |  |  |  |  |  |  |  |
| 2-03M |  | Accelerator Commissioned | milestone | 0d | 2013-12-19 | 2013-12-19 | 2811005, 2812005 |  |  |  | 21d | 0d | finish on or before 2014-09-30 |  |  | 0 |  | RODE C |  | 1 | 1 | 2 | M | CLAUS R | 2012-03-30 |  |  |  |  | PR |  |  |  |  |  |  |  |  | 12-029F |  | 11-026 | 12-025 |  |  |  |  |  |  |  |  |  |  |  |  |  |  |  |  |  |  |  |  |  |  |  |  |  |  |  |  |
| 2-25M |  | Box Supply Installtn Comptd | milestone | 0d | 2014-06-25 | 2014-06-25 | 13222100, 13222195, 23222100A, 13222035, 23221022c, 13222100A, 23222230, 23222035a, 23222230a, 13222142, 13222160, 23222142, 23222195, 13222067, 23222067a, 2813224000, 13221025 FS-2d, 13221025A, 13222065, 13222140, 23222035, 2813221000, 23222195a, 13222230, 2813221000a, 2813224000a |  |  |  | 0d |  |  |  |  | 0 | ACCL | HARWOOD L | 4 | 1 | 1 | 3 | M | LEIGH H |  |  |  |  |  | PR |  | 10-028 |  |  |  |  |  |  | 12-029 | 12-050 |  |  |  |  |  |  |  |  |  |  |  |  |  |  |  |  |  |  |  |  |  |  |  |  |  |  |  |  |  |  |
|  | 1.02H | **1.02H LEVEL 2 HALLS A, B & C MILESTONES** |  |  | 2007-10-01 | 2016-06-24 |  |  |  |  |  |  |  |  |  |  |  |  |  |  |  |  |  |  |  |  |  |  |  |  |  |  |  |  |  |  |  |  |  |  |  |  |  |  |  |  |  |  |  |  |  |  |  |  |  |  |  |  |  |  |  |  |  |  |  |  |  |  |  |  |
| 2-04M |  | Design Report on Superconducting Magnets | milestone | 0d | 2007-10-01 A | 2007-10-01 A |  | 100% | 2007-11-01 | 2007-11-01 |  |  | finish on or before 2007-09-28 |  |  | 0 |  | RODE C |  | 1 | 1 | 2 | N/A | CLAUS R | 2007-09-28 |  |  |  |  |  |  |  |  |  |  |  |  |  |  |  |  |  |  |  |  |  |  |  |  |  |  |  |  |  |  |  |  |  |  |  |  |  |  |  |  |  |  |  |  |  |
| 2-05M |  | Design Review on Superconducting Magnets | milestone | 0d | 2008-05-28 A | 2008-05-28 A | 122312080, 12221060M, 12221045M, 122311045M | 100% | 2008-06-02 | 2008-06-02 |  |  | finish on or before 2008-05-30 |  |  | 0 |  | RODE C |  | 1 | 1 | 2 | M | CLAUS R | 2008-03-31 |  |  | C | 5 |  |  |  |  |  |  |  |  |  |  |  |  |  | 08-052 |  |  |  |  |  |  |  |  |  |  |  |  |  |  |  |  |  |  |  |  |  |  |  |  |  |  |  |
| 2-06M |  | Award First Superconducting Magnet Contract | milestone | 0d | 2009-07-10 A | 2009-07-10 A | 3R-05M, 14312000M | 100% | 2009-08-03 | 2009-08-03 |  |  | finish on or before 2009-07-31 |  |  | 0 |  | RODE C |  | 1 | 1 | 2 | M | CLAUS R | 2009-03-31 |  |  |  |  |  |  |  |  |  |  |  |  |  |  |  |  |  |  |  |  |  |  |  |  |  |  |  |  |  |  |  |  |  |  |  |  |  |  |  |  |  |  |  |  |  |
| 2-07M |  | Start Installation for Existing Halls | milestone | 0d | 2012-09-01 A | 2012-09-01 A | 2-02M FS+40d, 14368010M | 100% | 2012-10-01 | 2012-10-01 |  |  | start on or before 2012-07-31 |  |  | 0 |  | RODE C |  | 1 | 1 | 2 | M | CLAUS R | 2011-03-31 |  |  |  |  |  |  |  |  |  |  |  |  |  |  |  |  |  |  | 09-030 | 09-030 |  |  |  |  |  |  |  |  |  |  |  |  |  |  |  |  |  |  |  |  |  |  |  |  |  |
| 2-08M |  | Installation of Experimental Equipment into H-A is Completed | milestone | 0d | 2013-12-20 | 2013-12-20 | 3A-43M, 24152025, 24153020 |  |  |  | 39d | 0d |  | 8/5 M-F w/JLAB Holidays ReBaseline |  | 0 |  | RODE C |  | 1 | 1 | 2 | M | CLAUS R | 2013-03-29 |  |  |  |  | PR |  |  |  |  |  |  |  |  |  |  |  | 12-025 |  |  |  |  |  |  |  |  |  |  |  |  |  |  |  |  |  |  |  |  |  |  |  |  |  |  |  |  |
| 2-09M |  | Hall-A Beam Commissioning Completed | milestone | 0d | 2014-03-12 | 2014-03-12 | 2811020, 2821X000, 2812065 |  |  |  | 13d | 0d | finish on or before 2014-03-31 |  |  | 0 |  | RODE C |  | 1 | 1 | 2 | M | CLAUS R |  |  |  |  |  | PR |  |  |  |  |  |  |  |  |  |  | 11-026 | 12-025 |  |  |  | 09-028 |  |  |  |  |  |  |  |  |  |  |  |  |  |  |  |  |  |  |  |  |  |  |  |  |
| 2-27M |  | Hall C Q1 Magnet Delivered | milestone | 0d | 2014-07-15 | 2014-07-15 | 24312053M |  |  |  | 77d | 0d | finish on or before 2014-10-31 | 8/5 M-F w/JLAB Holidays ReBaseline |  | 0 |  | FENKER H |  | 1 | 1 |  | M | HOWARD F |  |  |  |  |  | PR |  |  |  |  |  |  |  |  |  |  | 11-026 |  |  |  |  |  | 08-048 | 09-022 | 09-041 | 10-067 | 10-069 | 11-046 | 12-003 | 12-012 | 12-036 |  |  |  |  |  |  |  |  |  |  |  |  |  |  |  |
| 2-28M |  | Hall C HB Magnet Delivered | milestone | 0d | 2014-07-23 | 2014-07-23 | 24311160 FS-7d |  |  |  | 49d | 43d | finish on or before 2014-09-30 | 8/5 M-F w/JLAB Holidays ReBaseline |  | 0 |  | FENKER H |  | 1 | 1 |  | M | HOWARD F |  |  |  |  |  | PR |  |  |  |  |  |  |  |  |  |  | 11-026 |  |  |  |  |  | 08-048 | 09-022 |  |  | 10-069 | 11-046 |  | 12-012 | 12-036 | 10-063 | 10-074 | 11-017 | 11-025 |  |  |  |  |  |  |  |  |  |  |  |
| 2-34M |  | Hall B Torus Cold Mass Delivered | milestone | 0d | 2014-07-28 | 2014-07-28 | 24271740M |  |  |  | 45d | 0d | finish on or before 2014-09-30 | 8/5 M-F w/JLAB Holidays ReBaseline |  | 0 |  | ELOUADRHIRI L |  | 1 | 1 |  | M | LATIFA E |  |  |  |  |  | PR |  |  |  |  |  |  |  |  |  |  | 11-026 |  |  |  |  |  | 08-048 |  |  |  |  |  |  |  |  |  |  |  |  | 11 -035 | 12-024 | 13-002F |  |  |  |  |  |  |  |  |
| 2-29M |  | Hall C Dipole Delivered | milestone | 0d | 2015-05-18 | 2015-05-18 | 24314030a |  |  |  | 0d |  | finish on or before 2015-06-30 | 8/5 M-F w/JLAB Holidays ReBaseline |  | 0 |  | FENKER H |  | 1 | 1 |  | M | HOWARD F |  |  |  |  |  | PR |  |  |  |  |  |  |  |  |  |  | 11-026 |  |  |  |  |  | 08-048 | 09-022 |  |  | 10-069 | 11-046 |  | 12-012 | 12-036 |  |  | 11-017 |  |  |  |  | 10-008 | 10-076 |  |  |  |  |  |  |
| 2-30M |  | Hall C Q2 Magnet Delivered | milestone | 0d | 2015-06-19 | 2015-06-19 | 24313019a FS-72d |  |  |  | 18d | 12d | finish on or before 2015-07-31 | 8/5 M-F w/JLAB Holidays ReBaseline |  | 0 |  | FENKER H |  | 1 | 1 |  | M | HOWARD F |  |  |  |  |  | PR |  |  |  |  |  |  |  |  |  |  | 11-026 |  |  |  |  |  | 08-048 | 09-022 |  |  | 10-069 | 11-046 |  | 12-012 | 12-036 |  |  | 11-017 |  |  |  |  | 10-008 |  | Y |  |  |  |  |  |
| 2-31M |  | Hall C Q3 Magnet Delivered | milestone | 0d | 2015-08-26 | 2015-08-26 | 24313019a FS-25d |  |  |  | 6d |  | finish on or before 2015-09-30 | 8/5 M-F w/JLAB Holidays ReBaseline |  | 0 |  | FENKER H |  | 1 | 1 |  | M | HOWARD F |  |  |  |  |  | PR |  |  |  |  |  |  |  |  |  |  | 11-026 |  |  |  |  |  | 08-048 | 09-022 |  |  | 10-069 |  |  | 12-012 | 12-036 |  |  | 11-017 |  |  |  |  | 10-008 |  | Y |  |  |  |  |  |
| 2-35M |  | Hall B Solenoid Cryostated Coil Delivered | milestone | 0d | 2015-08-31 | 2015-08-31 | 24272075k, 24272075n, 242781005LOE |  |  |  | -167d | 0d | finish on or before 2014-12-31 | 8/5 M-F w/JLAB Holidays ReBaseline |  | 0 |  | ELOUADRHIRI L |  | 1 | 1 |  | M | LATIFA E |  |  |  |  |  | PR |  |  |  |  |  |  |  |  |  |  | 11-026 |  |  |  |  |  | 08-048 |  |  |  |  |  |  |  |  |  |  |  |  | 11 -035 | 12-024 | 13-002F |  |  |  |  |  |  |  |  |
| 2-32M |  | Installtn of Expermntl Equipmnt into H-C is Comptd | milestone | 0d | 2015-12-23 | 2015-12-23 | 143218P2LOE FS-500d, 243128PC13LOE5 FS-500d, 24313P6LOE5 FS-500d, 24315015Bb, 24362000, 24363041, 28236030, 143238P1LOEa FS-500d, 14315050LOEg FS-500d, 143118P3LOE FS-502d, 24312050d, 24312915LOE5 FS-500d, 24314051M, 24315090, 243161000, 24368052, 24368110, 24368590LOE FS-500d, 24353010a, 143248P1LOE5 FS-500d, 14314P4LOE FS-502d, 143128P5TLOE, 14353010, 24311071, 24314P6LOE FS-500d, 24368475, 24368505, 14362812LOE FS-500d, 143248P1LOE FS-500d, 14315050LOEf FS-500d, 14315095 FS-2d, 14351020 FS-2d, 24312055, 24315015Ba, 24363046, 24368540, 243118P6LOE FS-500d, 24368515, 24368545, 24311170, 24311165, 24315007 FS-2d, 243238P1LOEb, 24353010, 14368335M, 14314P4TLOE, 24311072a, 24311168, 24313270M FS-50d, 24314110 FS-500d, 24315050LOEg FS-500d, 24368450 FS-5d, 24368565, 24368570, 14368176, 14368425, 143238P1LOEb FS-500d, 14315050LOEd FS-500d, 143128PC13LOE, 243128PC13LOE FS-500d, 243128P6LOE5, 24368455 |  |  |  | 0d |  | finish on or before 2015-12-31 | 8/5 M-F w/JLAB Holidays ReBaseline |  | 0 |  | YOUNG G |  | 1 | 1 | 3 | M | YOUNG G |  |  |  |  |  | PR |  |  |  |  |  |  |  |  |  |  | 11-026 |  |  |  |  | 09-028 |  |  |  |  | 10-069 | 11-046 |  | 12-012 | 12-036 |  |  |  |  |  |  |  |  |  |  | 12-054 |  |  |  |  |
| 2-33M |  | Hall C Beam Commissioning Complete | milestone | 0d | 2016-02-08 | 2016-02-08 | 2811050, 2823X000, 2812035 |  |  |  | 38d | 0d | finish on or before 2016-03-31 | 8/5 M-F w/JLAB Holidays ReBaseline |  | 0 |  | YOUNG G |  | 1 | 1 | 3 | M | YOUNG G |  |  |  |  |  | PR |  |  |  |  |  |  | IPL |  |  |  | 11-026 |  |  |  |  | 09-028 |  |  |  |  |  |  |  | 12-012 | 12-036 |  |  |  |  |  |  |  |  |  |  | 12-054 | 2-33M | 09-028 | 13-006 |  |
| 2-36M |  | Installtn of Expermntl Equipmnt into H-B is Comptd | milestone | 0d | 2016-05-12 | 2016-05-12 | 14251005, 14254010, 24212005 FS-250d, 24231000, 24232025, 24233070M, 24264860M, 24264395, 24272410, 24273017, 242781025, 14235015, 242232685M, 24244030, 24254070, 24254050, 24254060, 24264281, 24264065M, 24264230, 24264390, 242742030, 242711.5010, 242751435a, 14271028LOEA, 14234005, 14264000bLOE FS-500d, 14264002LOE FS-500d, 14254007, 24212000 FS-250d, 242223570, 24244035, 24254020, 24254035, 24254115, 24264500, 24264440, 242781010LOE, 242711.5025, 14264280, 14264000dLOE FS-500d, 14244010, 242223575, 24235015, 24242060M, 24247060M, 24254005, 24254090, 24264878, 24264995, 24264003LOE FS-500d, 24264345, 24264470, 24271725 LOE, 24272085 FS-500d, 24272075r, 24273007, 242742025, 242751435, 242751450, 14211080 FS-250d, 14264230, 14264360, 14247015, 14242060M, 14254025, 24264888, 24271735, 24273027, 28223030, 28223025, 242742020a, 14247010, 14254020, 24211095 FS-250d, 242241457, 242241462, 24243010, 24254105, 24264006LOE FS-500d, 24271730, 28223040, 14212005s FS-250d, 14211051o FS-250d, 14264235, 14264410, 14244025, 14241015, 14252010, 24211090 FS-250d, 24254080, 24264360, 24264410, 24272405, 24273012, 24273022, 242742020, 24273012a, 242742030a, 242711.5010b, 14264345, 14254008, 242211620, 242241452, 24254000, 24254040 |  |  |  | -92d | 0d | finish on or before 2015-12-31 |  |  | 0 |  | YOUNG G |  | 1 | 1 | 3 | M | YOUNG G |  |  |  |  |  | PR |  |  |  |  |  |  |  |  |  |  | 11-026 |  |  |  |  |  |  |  |  |  |  |  |  |  |  |  |  |  |  |  | 12-024 |  |  |  |  |  |  |  |  |  |
| 2-37M |  | Hall B Beam Commissioning Complete | milestone | 0d | 2016-06-24 | 2016-06-24 | 2812020, 2822X000, 2811035 |  |  |  | -60d | 0d | finish on or before 2016-03-31 | 8/5 M-F w/JLAB Holidays ReBaseline |  | 0 |  | ELOUADRHIRI L |  | 1 | 1 | 3 | M | YOUNG G |  |  |  |  |  | PR |  |  |  |  |  |  | IPL |  |  |  | 11-026 |  |  |  |  | 09-028 |  |  |  |  |  |  |  |  |  |  |  |  |  |  | 12-024 | 13-002 |  |  |  |  | 2-37M | 09-028 |  | 13-010 |

Notes:
- 2-01M: Scope: added 05/04/07 in rev w JM and CR
- 2-04M: Scope: Design reports specifying the / reference designs of all new superconducting magnets are complete / Corrective Actions: Changed The Finish on or before date to 28Sept2007. per CHR 09 / Aug2007 (PMC)
- 2-05M: Scope: The first contract for fabrication of / a new Superconducting Magnet has been awarded
- 2-06M: Scope: The first contract for fabrication of / a new Superconducting Magnet has been awarded
- 2-07M: Scope: Installation of new experimental / equipment for Halls A, B, and C has started / Explanation: This milestone should have been claimed on the same date / as 3p-01. It was overlooked! PMK 10/11/12
- 2-08M: Scope: Installation of new experimental / equipment for Halls A, B, and C has finished
- 2-09M: Scope: Made level 2 from level 3 4/11/07 RKC renamed / from 3P-61M
- 2-32M: Scope: Installation of experimental equipment / into Hall C is complete
- 2-33M: Scope: Complete electron beam commissioning / of Hall C detectors, electronics, and beamline devices / Explanation: IPL from 6 GeV 5333065, 5333070 and 5333075 / Added FY14 Funding Predeccessor with 57.6 weeks lag to bring start date out / to match 6 GeV impact
- 2-36M: Scope: Installation of experimental equipment / into Hall B is complete
- 2-37M: Scope: Complete electron beam commissioning / of Hall B detectors, electronics, and beamline devices / Explanation: IPL from 6 GeV 5333065, 5333070 and 5333075 / Added FY14 Funding Predeccessor with 57.6 weeks lag to bring start date out / to match 6 GeV impact

| ID | WBS | Activity | Type | Duration | Start | Finish | Predecessors | Complete | Planned start | Planned finish | Total float | Free float | Constraint | PPEP Date | MONTHLY EV COST | RESP - Responsibility | STRT%COMP for CM EVM | FNSH%COMP for CM EVM | Milestone Level | 12 GeV 3rd level Critical Path | HALL D Related Milestones | CIVIL CRITICAL MILESTONES | EVMS Reporting Codes | CAM RESPONSIBLE | CR 10-042 | CR 10-061 | CR 11-004 | CR 11-036 | 12 GeV 1st level Critical Path | CR 09-014 | CR 11-006 | CR 11-026 | CR 12-021 | Post Rebaseline | GROP Group | CR 09-028 | CR 12-025 | CR 08-052 | CR 10-051 | CR 12-018 | CR 10-020 | CR 12-015 | Planned FinishUDF | Profile change | CR 08-002 | CR 07-032 | CR 09-031 | CR 09-031 Repair | CR 09-040 | CR 10-039 |
| --- | --- | --- | --- | --- | --- | --- | --- | --- | --- | --- | --- | --- | --- | --- | --- | --- | --- | --- | --- | --- | --- | --- | --- | --- | --- | --- | --- | --- | --- | --- | --- | --- | --- | --- | --- | --- | --- | --- | --- | --- | --- | --- | --- | --- | --- | --- | --- | --- | --- | --- |
|  | 1.02D1 | **1.02D LEVEL 2 HALL D MILESTONES** |  |  | 2010-11-24 | 2014-12-11 |  |  |  |  |  |  |  |  |  |  |  |  |  |  |  |  |  |  |  |  |  |  |  |  |  |  |  |  |  |  |  |  |  |  |  |  |  |  |  |  |  |  |  |  |
| 2-10M |  | Start Hall-D Installation | milestone | 0d | 2010-11-24 A | 2010-11-24 A | 2-16M | 100% | 2010-12-13 | 2010-12-13 |  |  | start on or before 2010-11-30 | 2009-09-30 | 0 | RODE C | 1 | 1 | 2 | 3 | D | CVL | M | CLAUS R | 10-042 | 10-061 |  |  |  |  |  |  |  |  |  |  |  |  |  |  |  |  |  |  |  |  |  |  |  |  |
| 2-11M |  | Installation of Hall-D Solenoid Completed | milestone | 0d | 2013-08-19 A | 2013-08-19 A | 151250M | 100% | 2013-09-03 | 2013-09-03 |  |  | finish on or before 2013-06-28 | 2011-03-31 | 0 | RODE C | 1 | 1 | 2 |  | D |  | M | CLAUS R | 10-042 |  | 11-004 | 11-036 |  |  |  |  |  |  |  |  |  |  |  |  |  |  |  |  |  |  |  |  |  |  |
| 2-12M |  | Hall-D Equipment Installation Completed | milestone | 0d | 2014-09-30 | 2014-09-30 | 1543013E, 1541013E, 1562685, 1562635, 1562650, 1562630, 1562655, 1562665, 15212195, 15211210, 25221005, 2531400, 2532075, 2532085, 2546615, 2546625, 2553210, 2553029, 2562625, 2562165, 2562235, 282462045, 2541015a, 2562895a, 1562260a, 1562595a, 1562645, 1562670, 25211250, 25211217, 2531360, 2532255, 2532014E FS-500d, 2532220, 2541154, 2542090, 2546620, 2546650, 2553011, 2562855, 2562091M, 1546182, 1553075, 1562405, 1562600, 1562270, 2531227aa5, 2531380, 2531370, 2532175a, 2543143, 2546655, 2562637, 2562785 FS-500d, 2562860, 2562615LOE FS-245d, 2562685, 2562006LOE FS-250d, 2562181, 25213030, 282462015, 282462010, 25211217a, 2553011a, 2562335b, 1562180, 1562345, 1562420, 1562330, 251666, 2532110, 2532115, 2532225, 2532235, 2543144, 2546645, 2562630, 2562635, 2562175, 2562790 FS-500d, 282462025, 282462030, 282462035, 2543144a, 2546620b, 2562482a, 13326000, 25221010LOE, 2531385, 2532000, 2532090, 2542085, 2553075, 2562780, 2562335, 282432005, 282462020, 2971000, 1562625, 3A-53M, 25211260, 25212010, 25212185, 25221010, 2531365 FS-500d, 2531395, 2531089, 2532180, 2532195, 2532240, 2541015, 2541155, 2546465, 2546630, 2562835, 2562895, 2562420, 2562445 FS-250d, 2562014E FS-250d, 2562170, 2562206, 282432010, 282462040, 295222000, 2532170aa, 2562181b, 2562445a, 282446000a, 1562260, 1562335, 15221012E, 13326015, 25211255LOE, 25211255LOE5, 25221000, 2531178, 2531227aa, 2532170a, 2541000, 2546565, 2562355, 2562900, 2562495, 2562460, 282432025, 282443025a, 282446000, 282462050, 25211260a, 2543165a, 2546610a, 2546650a, 1562670a, 1562595, 1562400, 13326010, 2531375, 2531088, 2532060, 2532245, 2542080, 2542037, 2543185, 2543160, 2543165, 2546610, 2546640, 2553157, 2562281, 2562482, 2562216, 2562885, 2562510, 2562595a FS-250d, 2562180, 282432015, 282443025a5, 2543160a, 2562355b, 282443025a5a |  |  |  | 0d |  | finish on or before 2014-09-30 | 2012-06-29 | 0 | RODE C | 1 | 1 | 2 |  | D | CVL | M | CLAUS R |  |  |  |  | 1 | 09-014 | 11-006 | 11-026 | 12-021 | PR |  |  |  |  |  |  |  |  |  |  |  |  |  |  |  |  |
| 2-13M |  | Hall-D Beam Commissioning Completed | milestone | 0d | 2014-12-11 | 2014-12-11 | 2812050, 2824X000, 13613035M, 2811065, 13422117, 28241000, 28241000a |  |  |  | 9d | 71d | finish on or before 2014-12-31 |  | 0 | RODE C | 1 | 1 | 2 |  | D |  | M | CLAUS R |  |  |  |  | 1 |  | 11-006 | 11-026 | 12-021 | PR | ACCL | 09-028 | 12-025 |  |  |  |  |  |  |  |  |  |  |  |  |  |
|  | 1.02C | **1.02C LEVEL 2 CIVIL MILESTONES** |  |  | 2008-09-26 | 2015-10-02 |  |  |  |  |  |  |  |  |  |  |  |  |  |  |  |  |  |  |  |  |  |  |  |  |  |  |  |  |  |  |  |  |  |  |  |  |  |  |  |  |  |  |  |  |
| 2-14M |  | Design of Conventional Facilties Completed | milestone | 0d | 2008-09-26 A | 2008-09-26 A | 1241155M, 3C-02M, 1241195M, 1241115M, 3C-01M, 1241075M | 100% | 2008-10-01 | 2008-10-01 |  |  | finish on or before 2008-09-30 | 2008-09-30 | 0 | RODE C | 1 | 1 | 2 |  |  |  | M | CLAUS R |  |  |  |  |  |  |  |  |  |  |  |  |  | 08-052 |  |  |  |  |  |  |  |  |  |  |  |  |
| 2-15M |  | Ready for Equipment - CHL Addition (RFE) (does not Include the Elect & Cooling Water Utility Distrbtn) | milestone | 0d | 2010-05-05 A | 2010-05-05 A | 1621010 | 100% | 2010-06-01 | 2010-06-01 |  |  | finish on or before 2010-09-30 | 2009-03-31 | 0 | RODE C | 1 | 1 | 2 |  | D |  | M | CLAUS R |  |  |  |  |  |  |  |  |  |  |  |  |  |  |  |  |  |  |  |  |  |  |  |  |  |  |
| 2-16M |  | Ready for Equipment - H-D (RFE) | milestone | 0d | 2010-12-28 A | 2010-12-28 A | 16331032, 16331030 | 100% | 2011-01-13 | 2011-01-13 |  |  | finish on or before 2010-11-30 | 2009-06-30 | 0 | RODE C | 1 | 1 | 2 | 3 | D | CVL | M | CLAUS R | 10-042 | 10-061 |  |  |  |  |  |  |  |  |  |  |  |  | 10-051 |  |  |  |  |  |  |  |  |  |  |  |
| 2-17M |  | Accelerator Tunnel Extension Completed (existing tunnel) | milestone | 0d | 2011-11-02 A | 2011-11-02 A | 16333030 | 100% | 2011-12-01 | 2011-12-01 |  |  | finish on or before 2012-07-31 | 2011-06-30 | 0 | RODE C | 1 | 1 | 2 |  |  |  | M | CLAUS R |  |  |  |  |  |  |  | 11-026 |  |  |  |  |  |  |  | 12-018F |  |  |  |  |  |  |  |  |  |  |
| 2-38M |  | Conventional Facilt's Comptd | milestone | 0d | 2015-10-02 | 2015-10-02 | 16333035, 16331035M, 16113030M, 16122030M, 16222035M, 16332035, 1621015b, 26112030M, 1621020, 26114030M, 16111030M, 1621030, 26115045M |  |  |  | 248d | 0d |  |  | 0 | YASKY R | 1 | 1 | 3 |  |  |  | M | REBECCA Y |  |  |  |  |  |  |  |  |  | PR |  |  |  |  |  |  | 10-020 | 12-015 |  |  |  |  |  |  |  |  |
|  | 1.02PM | **1.02PM LEVEL 2 PROJECT MANAGEMENT MILESTONES-1** |  |  | 2005-09-29 | 2008-06-26 |  |  |  |  |  |  |  |  |  |  |  |  |  |  |  |  |  |  |  |  |  |  |  |  |  |  |  |  |  |  |  |  |  |  |  |  |  |  |  |  |  |  |  |  |
| 2-18M |  | Preliminary Hazard Assessment Submitted to DOE | milestone | 0d | 2005-09-29 A | 2005-09-29 A |  | 100% |  |  |  |  |  | 2009-06-30 | 0 | RODE C | 1 | 1 | 2 |  |  |  | N/A | CLAUS R |  |  |  |  |  |  |  |  |  |  |  |  |  |  |  |  |  |  | 2005-09-29 |  |  |  |  |  |  |  |
| 2-19M |  | EA Completed | milestone | 0d | 2007-01-31 A | 2007-01-31 A | 1-2M | 100% | 2006-10-02 | 2006-10-02 |  |  | finish on or before 2006-10-02 | 2006-09-29 | 0 | RODE C | 1 | 1 | 2 |  |  |  | N/A | CLAUS R |  |  |  |  |  |  |  |  |  |  |  |  |  |  |  |  |  |  | 2006-10-02 |  |  |  |  |  |  |  |
| 2-20M |  | Completion of Land Transfer | milestone | 0d | 2007-10-04 A | 2007-10-04 A | 1-2M | 100% | 2007-11-01 | 2007-11-01 |  |  | finish on or before 2007-06-29 | 2006-09-29 | 0 | RODE C | 1 | 1 | 2 |  |  |  | N/A | CLAUS R |  |  |  |  |  |  |  |  |  |  |  |  |  |  |  |  |  |  | 2006-10-02 |  |  |  |  |  |  |  |
| 2-21M |  | PEP Issued | milestone | 0d | 2007-11-06 A | 2007-11-06 A | 1-2M | 100% | 2007-12-03 | 2007-12-03 |  |  | finish on or before 2007-09-28 |  | 0 | RODE C | 1 | 1 | 2 |  |  |  | N/A | CLAUS R |  |  |  |  |  |  |  |  |  |  |  |  |  |  |  |  |  |  | 2007-09-28 |  |  |  |  |  |  |  |
| 2-22M |  | OECM EVMS Contractor Certification REVIEW Complete | milestone | 0d | 2007-12-07 A | 2007-12-07 A | 1252015 | 100% |  |  |  |  | mandatory finish 2008-01-31 |  | 0 | RODE C | 1 | 1 | 2 |  |  |  | N/A | CLAUS R |  |  |  |  |  |  |  |  |  |  |  |  |  |  |  |  |  |  |  | C | 08-002 |  |  |  |  |  |
| 2-23M |  | Accelerator Safety Envelope (ASE) Completed | milestone | 0d | 2008-06-26 A | 2008-06-26 A | 9-080M FS+125d, 1251908LOEB FS-65d | 100% | 2008-07-30 | 2008-07-30 |  |  | finish on or before 2008-06-30 | 2007-06-29 | 0 | RODE C | 1 | 1 | 2 |  |  |  | M | CLAUS R |  |  |  |  |  |  |  |  |  |  |  |  |  |  |  |  |  |  |  | C |  | 07-032 |  |  |  |  |
| 2-24M |  | Safety Assessmnt Document (SAD) Completed | milestone | 0d | 2008-06-26 A | 2008-06-26 A | 1251908LOEB FS-65d, 9-080M FS+125d | 100% | 2008-07-30 | 2008-07-30 |  |  | finish on or before 2008-06-30 | 2007-06-29 | 0 | RODE C | 1 | 1 | 2 |  |  |  | M | CLAUS R |  |  |  |  |  |  |  |  |  |  |  |  |  |  |  |  |  |  |  | C |  | 07-032 |  |  |  |  |
|  | 1.02R | **1.02R LEVEL 2 REVIEW MILESTONES** |  |  |  |  |  |  |  |  |  |  |  |  |  |  |  |  |  |  |  |  |  |  |  |  |  |  |  |  |  |  |  |  |  |  |  |  |  |  |  |  |  |  |  |  |  |  |  |  |
|  | 1.02S | **1.02S LEVEL 2 STIMULUS MILESTONES** |  |  | 2009-05-29 | 2010-09-23 |  |  |  |  |  |  |  |  |  |  |  |  |  |  |  |  |  |  |  |  |  |  |  |  |  |  |  |  |  |  |  |  |  |  |  |  |  |  |  |  |  |  |  |  |
| 2-S01M |  | Award 4 Meter Dipole Magnet Subcontract | milestone | 0d | 2009-05-29 A | 2009-05-29 A | 13451060M | 100% | 2009-01-13 | 2009-01-13 |  |  | start on or before 2009-06-30 | 2010-12-31 | 0 | RODE C | 1 | 1 | 2 |  |  |  | M | CLAUS R |  |  |  |  |  |  |  |  |  |  |  |  |  |  |  |  |  |  |  |  |  |  | 09-031 | 09-031 |  |  |
| 2-S03M |  | Award Quad Magnets Subcontracts | milestone | 0d | 2009-06-30 A | 2009-06-30 A | 13452030M | 100% | 2009-07-01 | 2009-07-01 |  |  | start on or before 2009-06-30 | 2010-12-31 | 0 | RODE C | 1 | 1 | 2 |  |  |  | M | CLAUS R |  |  |  |  |  |  |  |  |  |  |  |  |  |  |  |  |  |  |  |  |  |  | 09-031 | 09-031 | 09-040 |  |
| 2-S04M |  | Award Cryomodules Spaceframes Subcontract | milestone | 0d | 2009-08-31 A | 2009-08-31 A | 131121010 | 100% | 2009-09-01 | 2009-09-01 |  |  | start on or before 2009-08-31 | 2010-12-31 | 0 | RODE C | 1 | 1 | 2 |  |  |  | M | CLAUS R |  |  |  |  |  |  |  |  |  |  |  |  |  |  |  |  |  |  |  |  |  |  | 09-031 | 09-031 |  |  |
| 2-S02M |  | Award Central Helium Liquifer 4.5K Coldbox Subcontract | milestone | 0d | 2009-09-30 A | 2009-09-30 A | 1331.02015, 1331.02000 FS-185d | 100% | 2009-10-01 | 2009-10-01 |  |  | start on or before 2009-06-30 | 2010-12-31 | 0 | RODE C | 1 | 1 | 2 |  |  |  | M | CLAUS R |  |  |  |  |  |  |  |  |  |  |  |  |  |  |  |  |  |  |  |  |  |  | 09-031 | 09-031 |  |  |
| 2-S05M |  | Award Cryomodules Vacuum Vessels Subcontract | milestone | 0d | 2009-11-25 A | 2009-11-25 A | 131136010 | 100% | 2009-12-01 | 2009-12-01 |  |  | start on or before 2009-11-30 | 2010-12-31 | 0 | RODE C | 1 | 1 | 2 |  |  |  | M | CLAUS R |  |  |  |  |  |  |  |  |  |  |  |  |  |  |  |  |  |  |  |  |  |  | 09-031 | 09-031 |  |  |
| 2-S06M |  | Award End Can Subcontract | milestone | 0d | 2009-12-23 A | 2009-12-23 A | 131135010 | 100% | 2010-01-04 | 2010-01-04 |  |  | start on or before 2009-12-21 | 2010-12-31 | 0 | RODE C | 1 | 1 | 2 |  |  |  | M | CLAUS R |  |  |  |  |  |  |  |  |  |  |  |  |  |  |  |  |  |  |  |  |  |  | 09-031 | 09-031 |  |  |
| 2-S10M |  | Award North & South Access Building Subcontract | milestone | 0d | 2010-01-13 A | 2010-01-13 A | 16111005 FS-1d, 16111000M | 100% | 2010-02-01 | 2010-02-01 |  |  | start on or before 2010-05-31 | 2010-12-31 | 0 | RODE C | 1 | 1 | 2 |  |  |  | M | CLAUS R |  |  |  |  |  |  |  |  |  |  |  |  |  |  |  |  |  |  |  |  |  |  | 09-031 | 09-031 |  |  |
| 2-S07M |  | Award High-Voltage Cathode Power Supply Subcontract | milestone | 0d | 2010-01-22 A | 2010-01-22 A | 1321121010 | 100% | 2010-02-01 | 2010-02-01 |  |  | start on or before 2010-01-29 | 2010-12-31 | 0 | RODE C | 1 | 1 | 2 |  |  |  | M | CLAUS R |  |  |  |  |  |  |  |  |  |  |  |  |  |  |  |  |  |  |  |  |  |  | 09-031 | 09-031 |  |  |
| 2-S08M |  | Award Central Helium Liquifer Compressors Subcontract | milestone | 0d | 2010-03-08 A | 2010-03-08 A | 1331.01000 FS-240d, 1331.01010 FS-77d | 100% | 2010-04-01 | 2010-04-01 |  |  | start on or before 2010-02-26 | 2010-12-31 | 0 | RODE C | 1 | 1 | 2 |  |  |  | M | CLAUS R |  |  |  |  |  |  |  |  |  |  |  |  |  |  |  |  |  |  |  |  |  |  | 09-031 | 09-031 |  | 10-039 |
| 2-S09M |  | Award Box Power Supply Subcontract | milestone | 0d | 2010-03-19 A | 2010-03-19 A | 13221004M | 100% | 2010-04-01 | 2010-04-01 |  |  | start on or before 2010-03-31 | 2010-12-31 | 0 | RODE C | 1 | 1 | 2 |  |  |  | M | CLAUS R |  |  |  |  |  |  |  |  |  |  |  |  |  |  |  |  |  |  |  |  |  |  | 09-031 | 09-031 |  |  |
| 2-S11M |  | Award Final Stimulus Subcontract | milestone | 0d | 2010-09-23 A | 2010-09-23 A | 1-6M | 100% | 2010-10-01 | 2010-10-01 |  |  | mandatory finish 2010-09-30 | 2010-12-31 | 0 | RODE C | 1 | 1 | 2 |  |  |  | M | CLAUS R |  |  |  |  |  |  |  |  |  |  |  |  |  |  |  |  |  |  |  |  |  |  | 09-031 | 09-031 |  |  |

Notes:
- 2-10M: Scope: Installation of new experimental / equipment into Hall D or the tagging area has begun
- 2-11M: Scope: Installation of the Hall D solenoid / magnet, including its modified flux return yoke, has been / completed
- 2-12M: Scope: Installation of all experimental / equipment into Hall D and the tagger area is complete
- 2-13M: Scope: Made level 2 from level 3 4/11/07 RKC Renamed from 3P-63M
- 2-14M: Scope: Complete / all Civil design work - both in-house and A-E designs packages. Milestones 3-09M and 3-10M are / predecessors.
- 2-15M: Scope: Civil / construction completion of the CHL building addition and ready for equipment / installation to start. It does not / include the electrical and cooling water utility / distribution.
- 2-16M: Scope: Civil / construction completion of Experimental Hall D and ready for equipment / installation to start.
- 2-17M: Scope: Connection / of the new tunnel extension to the existing Accelerator tunnel is / complete.

| ID | WBS | Activity | Type | Duration | Start | Finish | Predecessors | Complete | Planned start | Planned finish | Total float | Free float | Constraint | PPEP Date | MONTHLY EV COST | RESP - Responsibility | STRT%COMP for CM EVM | FNSH%COMP for CM EVM | Milestone Level | EVMS Reporting Codes | CAM RESPONSIBLE | CR 09-023 | GROP Group | MILE - Milestone | CR 09-053 | CR 12-028 | CR 08-009 | CR 08-052 | CR 12-037 | CR 10-059 | CR 11-044 | CR 10-065 | CR 12-035 | CR 10-028 | CR 11-042 | CR 10-031 | CR 10-064 | CR 10-066 | CR 12-018 | Inter Project Link (IPL) | CR 11-051 | MARCH!!! | CR 11-015 | CR 10-040 | CR 11-055 | CR 12-029 | CR 12-050 | CR 12-025 | Post Rebaseline | CR 11-026 | CR 10-070 |
| --- | --- | --- | --- | --- | --- | --- | --- | --- | --- | --- | --- | --- | --- | --- | --- | --- | --- | --- | --- | --- | --- | --- | --- | --- | --- | --- | --- | --- | --- | --- | --- | --- | --- | --- | --- | --- | --- | --- | --- | --- | --- | --- | --- | --- | --- | --- | --- | --- | --- | --- | --- |
|  | 1.03A | **1.03A LEVEL 3 ACCELERATOR MILESTONES** |  |  | 2009-04-21 | 2014-03-07 |  |  |  |  |  |  |  |  |  |  |  |  |  |  |  |  |  |  |  |  |  |  |  |  |  |  |  |  |  |  |  |  |  |  |  |  |  |  |  |  |  |  |  |  |  |
| 32-01M |  | Award Initial Major Acc contract | milestone | 0d | 2009-04-21 A | 2009-04-21 A | 132111025M | 100% | 2009-05-01 | 2009-05-01 |  |  |  | 2010-12-31 | 0 | HARWOOD L | 1 | 1 | 3 | M | LEIGH H | 09-023 |  |  |  |  |  |  |  |  |  |  |  |  |  |  |  |  |  |  |  |  |  |  |  |  |  |  |  |  |  |
| 3A-01M |  | Start Linac Installtn | milestone | 0d | 2010-01-04 A | 2010-01-04 A | 9-100M FS+60d | 100% |  |  |  |  | start on or before 2011-06-30 |  | 0 | HARWOOD L | 1 | 1 | 3 | M | LEIGH H |  | ACCL | 4 |  |  |  |  |  |  |  |  |  |  |  |  |  |  |  |  |  |  |  |  |  |  |  |  |  |  |  |
| 32-02M |  | Vendor Preliminary Dsgn Review of 4K Coldbox | milestone | 0d | 2010-02-10 A | 2010-02-10 A | 1331.02025 | 100% | 2010-04-01 | 2010-04-01 |  |  | finish on or before 2010-01-31 | 2008-06-30 | 0 | HARWOOD L | 1 | 1 | 3 | M | LEIGH H |  |  |  | 09-053 |  |  |  |  |  |  |  |  |  |  |  |  |  |  |  |  |  |  |  |  |  |  |  |  |  |  |
| 32-03M |  | Start Accel Component Assy | milestone | 0d | 2010-04-01 A | 2010-04-01 A | 132113060 | 100% | 2010-05-03 | 2010-05-03 |  |  | start on or before 2010-06-30 | 2008-12-31 | 0 | HARWOOD L | 1 | 1 | 3 | M | LEIGH H |  |  |  |  | 12-028F |  |  |  |  |  |  |  |  |  |  |  |  |  |  |  |  |  |  |  |  |  |  |  |  |  |
| 3A-02M |  | Start LLRF Installtn | milestone | 0d | 2010-10-01 A | 2010-10-01 A | 9-110M | 100% | 2010-11-01 | 2010-11-01 |  |  | start on or before 2011-05-31 |  | 0 | HARWOOD L | 1 | 1 | 3 | M | LEIGH H |  | ACCL | 4 |  |  | 08-009 | 08-052 |  |  |  |  |  |  |  |  |  |  |  |  |  |  |  |  |  |  |  |  |  |  |  |
| 3A-08M |  | Start MPS Installtn | milestone | 0d | 2011-06-01 A | 2011-06-01 A | 3A-09M, 16331032, 16331030, 16332030 FS-250d, 13641014 | 100% | 2012-03-19 | 2012-03-19 |  |  | start on or before 2012-04-30 |  | 0 | HARWOOD L | 1 | 1 | 3 | M | LEIGH H |  | ACCL | 4 |  |  |  |  | 12-037F |  |  |  |  |  |  |  |  |  |  |  |  |  |  |  |  |  |  |  |  |  |  |
| 3A-09M |  | Start I&C/Sfty Installtn | milestone | 0d | 2011-06-01 A | 2011-06-01 A | 13643085 FS-160d, 13643090 FS-160d | 100% | 2012-02-03 | 2012-02-03 |  |  | start on or before 2012-01-31 |  | 0 | HARWOOD L | 1 | 1 | 3 | M | LEIGH H |  | ACCL | 4 |  |  |  |  |  | 10-059 | 11-044 |  |  |  |  |  |  |  |  |  |  |  |  |  |  |  |  |  |  |  |  |
| 3A-13M |  | Start West Arc Removl | milestone | 0d | 2011-06-01 A | 2011-06-01 A | 2-02M | 100% | 2012-05-14 | 2012-05-14 |  |  |  |  | 0 | HARWOOD L | 1 | 1 | 3 | M | LEIGH H |  | ACCL | 4 |  |  |  |  |  |  |  | 10-065 | 12-035 |  |  |  |  |  |  |  |  |  |  |  |  |  |  |  |  |  |  |
| 3A-14M |  | Start East Arc Removl | milestone | 0d | 2011-06-01 A | 2011-06-01 A | 2-02M | 100% | 2012-05-14 | 2012-05-14 |  |  |  |  | 0 | HARWOOD L | 1 | 1 | 3 | M | LEIGH H |  | ACCL | 4 |  |  |  |  |  |  |  | 10-065 | 12-035 |  |  |  |  |  |  |  |  |  |  |  |  |  |  |  |  |  |  |
| 3A-21M |  | Start Pwr (Mag) Installtn | milestone | 0d | 2011-06-01 A | 2011-06-01 A | 13224015, 13224025, 13224030, 13224010, 9-110M FS+170d, 13224020, 13224005 | 100% | 2012-03-16 | 2012-03-16 |  |  | start on or before 2012-09-28 |  | 0 | HARWOOD L | 1 | 1 | 3 | M | LEIGH H |  | ACCL | 4 |  |  |  |  |  |  |  |  |  | 10-028 | 11-042 |  |  |  |  |  |  |  |  |  |  |  |  |  |  |  |  |
| 3A-03M |  | Start Pwr (rf) Installtn | milestone | 0d | 2011-06-01 A | 2011-06-01 A | 4A-03M | 100% | 2011-07-18 | 2011-07-18 |  |  | start on or before 2012-01-31 |  | 0 | HARWOOD L | 1 | 1 | 3 | M | LEIGH H |  | ACCL | 4 |  | 12-028F |  |  |  |  |  |  |  | 10-028 |  | 10-031 | 10-064 | 10-066 | 12-018F |  |  |  |  |  |  |  |  |  |  |  |  |
| 3A-07M |  | Start PSS Installtn | milestone | 0d | 2011-06-01 A | 2011-06-01 A | 3A-09M FS+20d, 16331032, 16331030 | 100% | 2011-07-01 | 2011-07-01 |  |  |  |  | 0 | HARWOOD L | 1 | 1 | 3 | M | LEIGH H |  | ACCL | 4 |  |  |  |  |  | 10-059 | 11-044 |  |  |  |  |  |  |  |  |  |  |  |  |  |  |  |  |  |  |  |  |
| 3A-34M |  | Start West Arc Installtn | milestone | 0d | 2011-06-01 A | 2011-06-01 A | 2-02M, 3A-29M | 100% | 2012-10-17 | 2012-10-17 |  |  |  |  | 0 | HARWOOD L | 1 | 1 | 3 | M | LEIGH H |  | ACCL | 4 |  |  |  |  |  |  |  | 10-065 | 12-035 |  |  |  |  |  |  |  |  |  |  |  |  |  |  |  |  |  |  |
| 3A-36M |  | Start East Arc Installtn | milestone | 0d | 2011-06-01 A | 2011-06-01 A | 2-02M, 3A-30M | 100% | 2012-10-17 | 2012-10-17 |  |  |  |  | 0 | HARWOOD L | 1 | 1 | 3 | M | LEIGH H |  | ACCL | 4 |  |  |  |  |  |  |  | 10-065 | 12-035 |  |  |  |  |  |  |  |  |  |  |  |  |  |  |  |  |  |  |
| 3A-29M |  | West Arc Removl Comptd | milestone | 0d | 2011-06-01 A | 2011-06-01 A |  | 100% | 2012-10-16 | 2012-10-16 |  |  |  |  | 0 | HARWOOD L | 1 | 1 | 3 | M | LEIGH H |  | ACCL | 4 |  |  |  |  |  |  |  | 10-065 | 12-035 |  |  |  |  |  |  |  |  |  |  |  |  |  |  |  |  |  |  |
| 3A-20M |  | Start Cryomodule Installtn | milestone | 0d | 2011-08-02 A | 2011-08-02 A | 3A-01M, 131401000 | 100% | 2011-11-16 | 2011-11-16 |  |  | start on or before 2012-09-28 |  | 0 | HARWOOD L | 1 | 1 | 3 | M | LEIGH H |  | ACCL | 4 |  |  |  |  |  |  |  | 10-065 |  |  |  | 10-031 | 10-064 | 10-066 |  |  |  |  |  |  |  |  |  |  |  |  |  |
| 3A-04M |  | Start 2nd Cryogenics Plant Commssng (IPL) | milestone | 0d | 2011-10-03 A | 2011-10-03 A | 1621015b FS+130d, 1331.07000b, 1331.02015 FS-1d, 1331.01110 FS-125d, 1331.02012, 1331.06000, 1621020 FS+130d, 16222035M, 12131.11010, 1331.02070 FS-100d, 1331.09000 FS+60d, 1331.03000, 1331.10000 FS-100d, 9-120M, 1331.02001, 3C-07M, 1331.08000, 1331.1000a FS-100d, 1331.01005A, 1331.12000 FS-100d, 1331.07000a FS-100d, 1331.02000, 1331.1000b FS-100d, 1331.01000 | 100% | 2012-05-08 | 2012-05-08 |  |  | start on or before 2011-11-30 |  | 0 | HARWOOD L | 1 | 1 | 3 | M | LEIGH H |  | CVL | 4 |  |  |  |  |  |  |  |  |  |  |  |  |  |  |  | IPL |  |  |  |  |  |  |  |  |  |  |  |
| 3A-59M |  | Test Lab Ready for Renovation | milestone | 0d | 2012-05-01 A | 2012-05-01 A |  | 100% | 2012-06-01 | 2012-06-01 |  |  | mandatory finish 2012-05-01 |  | 0 | HARWOOD L | 1 | 1 | 3 | M | LEIGH H |  |  |  |  |  |  |  |  |  |  |  |  |  |  |  |  |  | 12-018 |  | 11-051 |  |  |  |  |  |  |  |  |  |  |
| 3A-19M |  | Start S/R Removl | milestone | 0d | 2012-05-21 A | 2012-05-21 A | 2-02M | 100% | 2012-06-01 | 2012-06-01 |  |  |  |  | 0 | HARWOOD L | 1 | 1 | 3 | M | LEIGH H |  | ACCL | 4 |  |  |  |  |  |  |  | 10-065 | 12-035 |  |  |  |  |  |  | IPL |  |  |  |  |  |  |  |  |  |  |  |
| 3A-22M |  | Start Trim Supply Installtn | milestone | 0d | 2012-05-21 A | 2012-05-21 A | 2-02M | 100% | 2012-06-01 | 2012-06-01 |  |  |  |  | 0 | HARWOOD L | 1 | 1 | 3 | M | LEIGH H |  | ACCL | 4 |  | 12-028 |  |  |  |  |  |  |  | 10-028 |  |  |  |  |  |  |  |  |  |  |  |  |  |  |  |  |  |
| 3A-16M |  | Start H-A BL Removl | milestone | 0d | 2012-08-13 A | 2012-08-13 A | 2-02M | 100% | 2012-09-04 | 2012-09-04 |  |  |  |  | 0 | HARWOOD L | 1 | 1 | 3 | M | LEIGH H |  | ACCL | 4 |  |  |  |  |  |  |  | 10-065 | 12-035 |  |  |  |  |  |  |  |  |  |  |  |  |  |  |  |  |  |  |
| 3A-17M |  | Start H-B BL Removl | milestone | 0d | 2012-08-13 A | 2012-08-13 A | 2-02M | 100% | 2012-09-04 | 2012-09-04 |  |  |  |  | 0 | HARWOOD L | 1 | 1 | 3 | M | LEIGH H |  | ACCL | 4 |  |  |  |  |  |  |  | 10-065 | 12-035 |  |  |  |  |  |  |  |  |  |  |  |  |  |  |  |  |  |  |
| 3A-18M |  | Start H-C BL Removl | milestone | 0d | 2012-08-13 A | 2012-08-13 A | 2-02M | 100% | 2012-09-04 | 2012-09-04 |  |  |  |  | 0 | HARWOOD L | 1 | 1 | 3 | M | LEIGH H |  | ACCL | 4 |  |  |  |  |  |  |  | 10-065 | 12-035 |  |  |  |  |  |  |  |  |  |  |  |  |  |  |  |  |  |  |
| 3A-12M |  | Start H-D BL Installtn | milestone | 0d | 2012-09-04 A | 2012-09-04 A | 2-02M | 100% | 2012-10-01 | 2012-10-01 |  |  |  |  | 0 | HARWOOD L | 1 | 1 | 3 | M | LEIGH H |  | ACCL | 4 |  |  |  |  |  |  |  |  | 12-035 |  |  |  |  |  |  |  |  |  |  |  |  |  |  |  |  |  |  |
| 3A-30M |  | East Arc Removl Comptd | milestone | 0d | 2012-09-17 A | 2012-09-17 A | 13427020 | 100% | 2012-10-01 | 2012-10-01 |  |  |  |  | 0 | HARWOOD L | 1 | 1 | 3 | M | LEIGH H |  | ACCL | 4 |  |  |  |  |  |  |  | 10-065 | 12-035 |  |  |  |  |  |  |  |  |  |  |  |  |  |  |  |  |  |  |
| 3A-28M |  | H-A BL Removl Comptd | milestone | 0d | 2013-05-13 A | 2013-05-13 A | 13427035 | 100% | 2013-06-03 | 2013-06-03 |  |  |  |  | 0 | HARWOOD L | 1 | 1 | 3 | M | LEIGH H |  |  |  |  |  |  |  |  |  |  | 10-065 | 12-035 |  |  |  |  |  |  |  |  | XX |  |  |  |  |  |  |  |  |  |
| 3A-31M |  | H-B BL Removl Comptd | milestone | 0d | 2013-05-15 A | 2013-05-15 A | 13427042 | 100% | 2013-06-03 | 2013-06-03 |  |  |  |  | 0 | HARWOOD L | 1 | 1 | 3 | M | LEIGH H |  | ACCL | 4 |  |  |  |  |  |  |  | 10-065 | 12-035 |  |  |  |  |  |  |  |  | XX |  |  |  |  |  |  |  |  |  |
| 3A-32M |  | H-C BL Removl Comptd | milestone | 0d | 2013-05-20 A | 2013-05-20 A | 13427050 | 100% | 2013-06-03 | 2013-06-03 |  |  |  |  | 0 | HARWOOD L | 1 | 1 | 3 | M | LEIGH H |  | ACCL | 4 |  |  |  |  |  |  |  | 10-065 | 12-035 |  |  |  |  |  |  |  |  | XX |  |  |  |  |  |  |  |  |  |
| 3A-38M |  | Start H-B BL Installtn | milestone | 0d | 2013-06-01 A | 2013-06-01 A | 2-02M, 3A-31M, 3A-17M | 100% | 2013-07-01 | 2013-07-01 |  |  |  |  | 0 | HARWOOD L | 1 | 1 | 3 | M | LEIGH H |  | ACCL | 4 |  |  |  |  |  |  |  | 10-065 | 12-035 |  |  |  |  |  |  |  |  | XX |  |  |  |  |  |  |  |  |  |
| 3A-37M |  | Start H-A BL Installtn | milestone | 0d | 2013-07-15 A | 2013-07-15 A | 3A-16M, 3A-28M, 2-02M | 100% | 2013-08-01 | 2013-08-01 |  |  |  |  | 0 | HARWOOD L | 1 | 1 | 3 | M | LEIGH H |  | ACCL | 4 |  |  |  |  |  |  |  | 10-065 | 12-035 |  |  |  |  |  |  |  |  | XX |  |  |  |  |  |  |  |  |  |
| 3A-52M |  | East arc Installtn Comptd | milestone | 0d | 2013-07-15 A | 2013-07-15 A | 13427032 | 100% | 2013-08-01 | 2013-08-01 |  |  |  |  | 0 | HARWOOD L | 1 | 1 | 3 | M | LEIGH H |  | ACCL | 4 |  | 12-028 |  |  |  |  |  | 10-065 | 12-035 |  |  |  |  |  |  | IPL |  | XX |  |  |  |  |  |  |  |  |  |
| 3A-40M |  | HPA Installtn Comptd | milestone | 0d | 2013-08-09 A | 2013-08-09 A | 132111115M, 132112090M, 132111057M | 100% | 2013-09-03 | 2013-09-03 |  |  |  |  | 0 | HARWOOD L | 1 | 1 | 3 | M | LEIGH H | 09-023 | ACCL | 4 |  | 12-028 |  |  |  |  |  |  |  | 10-028 |  |  |  |  |  |  |  |  | 11-015 |  |  |  |  |  |  |  |  |
| 3A-33M |  | Start H-C BL Installtn | milestone | 0d | 2013-08-19 A | 2013-08-19 A | 2-02M, 3A-32M, 3A-18M | 100% | 2013-09-03 | 2013-09-03 |  |  |  |  | 0 | HARWOOD L | 1 | 1 | 3 | M | LEIGH H |  | ACCL | 4 |  |  |  |  |  |  |  | 10-065 | 12-035 |  |  |  |  |  |  |  |  | XX |  |  |  |  |  |  |  |  |  |
| 3A-56M |  | West arc Installtn Comptd | milestone | 0d | 2013-08-26 A | 2013-08-26 A | 13427030 | 100% | 2013-09-03 | 2013-09-03 |  |  |  |  | 0 | HARWOOD L | 1 | 1 | 3 | M | LEIGH H |  | ACCL | 4 |  |  |  |  |  |  |  | 10-065 | 12-035 |  |  |  |  |  |  | IPL |  |  |  |  |  |  |  |  |  |  |  |
| 3A-10M |  | LLRF Installtn Comptd | milestone | 0d | 2013-08-30 A | 2013-08-30 A | 132121070M | 100% | 2013-09-03 | 2013-09-03 |  |  |  |  | 0 | HARWOOD L | 1 | 1 | 3 | M | LEIGH H |  | ACCL | 4 |  | 12-028 | 08-009 |  |  |  |  |  |  | 10-028 |  |  |  |  |  |  |  | XX |  |  |  |  |  |  |  |  |  |
| 3A-23M |  | Start Box Supply Installtn | milestone | 0d | 2013-08-30 A | 2013-08-30 A | 23221024ba FS-320d, 16111025, 13221024a FS-320d, 13221030, 13221020a FS-207d | 100% | 2013-09-03 | 2013-09-03 |  |  |  |  | 0 | HARWOOD L | 1 | 1 | 3 | M | LEIGH H |  | ACCL | 4 |  |  |  |  |  |  |  |  |  | 10-028 |  |  |  |  |  |  |  |  |  | 10-040 | 11-055 | 12-029 | 12-050 |  |  |  |  |
| 3A-41M |  | Pwr (rf) Installtn Comptd | milestone | 0d | 2013-08-30 A | 2013-08-30 A | 3A-40M, 3A-10M, 132113090M | 100% | 2013-09-03 | 2013-09-03 |  |  |  |  | 0 | HARWOOD L | 1 | 1 | 3 | M | LEIGH H |  | ACCL | 4 |  | 12-028 |  |  |  |  |  |  |  |  |  |  |  |  |  |  |  |  |  |  |  |  |  |  |  |  |  |
| 3A-58M |  | End of Long Accel Constr Down | milestone | 0d | 2013-10-01 A | 2013-10-01 A | 13417040a, 13427016LOE, 1367050, 23411145 FS-25d, 23463050 FS-20d, 13417020, 13411150LOE, 13422060, 23417150 FS-45d, 23417165 FS-15d, 23417170 FS-15d, 23447010 FS-5d, 23223125 FS-100d, 13427021a, 1352020, 13611026b, 23417065 FS-15d, 23463050a FS-20d, 13417170, 13417030, 13458045, 13427050, 13427030, 132113135, 23613913LOE FS-100d, 13455145, 13427022a, 13427023a, 23427016LOE FS-45d, 23612913LOE FS-100d, 13447010, 13436040, 13416049, 13417150, 13417035, 13441010, 13427024a, 13223125, 2363913LOE FS-100d, 23643355 FS-60d, 23223125b FS-100d, 23411145a FS-25d, 23427016LOEa FS-45d, 13643355, 13643360, 23611026b FS-15d, 2365913LOE FS-100d, 23223125a FS-100d, 232111914LOE FS-500d | 100% | 2013-11-01 | 2013-11-01 |  |  | mandatory finish 2013-09-13 |  | 0 | HARWOOD L | 1 | 1 | 3 | M | LEIGH H |  |  |  |  |  |  |  |  |  |  |  |  |  |  |  |  |  |  |  |  |  |  |  |  |  |  | 12-025 | PR |  |  |
| 32-05M |  | Start Accel Beam Commssng | milestone | 0d | 2013-11-13 | 2013-11-13 | 1363015b, 13461045M, 2811001 FS-20d, 1363015aa, 2363015aa, 2-26M FS-11d |  |  |  | 19d | 0d |  |  | 0 | HARWOOD L | 1 | 1 | 3 | M | LEIGH H |  | ACCL | 4 |  |  |  |  |  |  |  |  |  |  |  |  |  |  |  |  |  |  |  |  |  | 12-029 |  | 12-025 | PR | 11-026 |  |
| 3A-44M |  | H-B BL Installtn Comptd | milestone | 0d | 2013-11-14 | 2013-11-14 | 13221115, 23427047a, 13427047, 23427047 |  |  |  | 30d | 9d |  |  | 0 | HARWOOD L | 1 | 1 | 3 | M | LEIGH H |  | ACCL | 4 |  |  |  |  |  |  |  | 10-065 | 12-035 |  |  |  |  |  | 12-018F |  |  |  |  |  |  | 12-029F |  | 12-025 | PR |  |  |
| 3A-47M |  | Cryomodule Installtn Comptd | milestone | 0d | 2013-11-20 | 2013-11-20 | 181315025, 281315025, 281315015 |  |  |  | 26d | 0d |  |  | 0 | HARWOOD L | 1 | 1 | 3 | M | LEIGH H |  | ACCL | 4 |  | 12-028 |  |  |  |  |  |  |  |  |  |  | 10-064 | 10-066 | 12-018 |  |  |  |  |  |  |  |  |  | PR |  |  |
| 3A-43M |  | H-A BL Installtn Comptd | milestone | 0d | 2013-11-27 | 2013-11-27 | 23427040a, 23427040, 13221115, 13427040 |  |  |  | 21d | 0d |  |  | 0 | HARWOOD L | 1 | 1 | 3 | M | LEIGH H |  | ACCL | 4 |  |  |  |  |  |  |  | 10-065 | 12-035 |  |  |  |  |  | 12-018F |  |  |  |  |  |  | 12-029F |  | 12-025 | PR |  |  |
| 3A-46M |  | H-C BL Installtn Comptd | milestone | 0d | 2013-11-27 | 2013-11-27 | 13221115, 23427057, 13427057 |  |  |  | 21d | 0d |  |  | 0 | HARWOOD L | 1 | 1 | 3 | M | LEIGH H |  | ACCL | 4 |  |  |  |  |  |  |  | 10-065 | 12-035 |  |  |  |  |  | 12-018F |  |  |  |  |  |  | 12-029F |  | 12-025 | PR |  |  |
| 3A-54M |  | S/R Installtn Comptd | milestone | 0d | 2013-11-27 | 2013-11-27 | 13417145, 13411145 FS+40d, 23417145a, 13417040a, 23417145 |  |  |  | 21d | 0d |  |  | 0 | HARWOOD L | 1 | 1 | 3 | M | LEIGH H |  | ACCL | 4 |  |  |  |  |  |  |  | 10-065 | 12-035 |  |  |  |  |  |  | IPL |  |  |  |  |  |  |  |  | PR |  |  |
| 3A-49M |  | PSS Installtn Comptd | milestone | 0d | 2014-01-15 | 2014-01-15 | 13643170M, 13643165, 13643075, 23643117, 23643105a, 13643345, 13643120, 13643105, 13643172M, 13643140, 13643070, 23643105, 23643170M, 23643117b, 23643140a, 23643140, 23643165 |  |  |  | 61d | 45d |  |  | 0 | HARWOOD L | 1 | 1 | 3 | M | LEIGH H |  | ACCL | 4 |  |  |  |  | 12-037 |  |  |  |  |  |  |  |  | 10-066 |  |  |  |  |  |  |  |  |  |  | PR |  | 10-070 |
| 3A-53M |  | H-D BL Installtn Comptd | milestone | 0d | 2014-02-20 | 2014-02-20 | 1363020b, 1366055M, 1365035M, 2562435, 13458065, 23458065a, 13643185M, 1365065M, 2365035M, 2366055M, 2532020, 23458065, 13221115, 1363020a, 2367025aa, 2365065M, 2367025a |  |  |  | 37d | 6d |  |  | 0 | HARWOOD L | 1 | 1 | 3 | M | LEIGH H |  | ACCL | 4 |  |  |  |  |  |  |  |  | 12-035 |  |  |  |  |  | 12-018F |  |  |  |  |  |  | 12-029F |  | 12-025 | PR | 11-026 |  |
| 3A-42M |  | MPS Installtn Comptd | milestone | 0d | 2014-02-28 | 2014-02-28 | 13641100M, 13641045M, 23641080M, 23641045M, 13641080M |  |  |  | 58d | 0d |  |  | 0 | HARWOOD L | 1 | 1 | 3 | M | LEIGH H |  | ACCL | 4 |  |  |  |  | 12-037 |  |  |  |  |  |  |  |  |  |  |  |  |  |  |  |  |  |  |  | PR |  |  |
| 3A-48M |  | Trim Supply Installtn Comptd | milestone | 0d | 2014-03-07 | 2014-03-07 | 13223025, 13224110, 13223060, 23223015, 23223051Q FS-15d, 23223060a, 2813224005, 23223015a, 23223025a, 13224003LOE FS-100d, 23224003LOE FS-100d, 23223025, 13223015 |  |  |  | 13d | 0d |  |  | 0 | HARWOOD L | 1 | 1 | 3 | M | LEIGH H |  | ACCL | 4 |  | 12-028 |  |  |  |  |  |  |  | 10-028 |  |  |  |  |  |  |  |  |  |  |  |  |  |  | PR |  |  |

Notes:
- 32-02M: Scope: CHL Final Design Review / Explanation: Orginial Finish date was on or before 31 August 09. Date / was changed by CR09-053, which details when this milestone will be / complete. New date 31 Jan 10.

| ID | WBS | Activity | Type | Duration | Start | Finish | Predecessors | Complete | Planned start | Planned finish | Total float | Free float | Constraint | Calendar | MONTHLY EV COST | GROP Group | RESP - Responsibility | MILE - Milestone | STRT%COMP for CM EVM | FNSH%COMP for CM EVM | Milestone Level | Profile change | EVMS Reporting Codes | CAM RESPONSIBLE | CR 08-052 | CR 09-044 | CR 10-061 | CR 12-015 | CR 10-033 | 12 GeV 2nd level Critical Path | CIVIL CRITICAL MILESTONES | CR 08-023 | CR 10-059 | CR 11-020 | CR 10-021 | CR 11-044 | CR 10-020 | CR 11-001 | PPEP Date | HALL D Related Milestones | Inter Project Link (IPL) | CR 09-028 | CR 09-028 Repair | CR 11-004 | CR 11-026 | CR 10-048 | CR 11-036 | CR 11-046 | CR 12-012 | CR 12-036 | CR 13-006 | MARCH!!! | CR 12-025 | Post Rebaseline | Original Activity ID Rebaseline | 12 GeV 1st level Critical Path | CR 11-006 | CR 12-021 | CR 10-069 | CR 12-054 | CR 12-024 |
| --- | --- | --- | --- | --- | --- | --- | --- | --- | --- | --- | --- | --- | --- | --- | --- | --- | --- | --- | --- | --- | --- | --- | --- | --- | --- | --- | --- | --- | --- | --- | --- | --- | --- | --- | --- | --- | --- | --- | --- | --- | --- | --- | --- | --- | --- | --- | --- | --- | --- | --- | --- | --- | --- | --- | --- | --- | --- | --- | --- | --- | --- |
|  | 1.03C | **1.03C LEVEL 3 CIVIL MILESTONES** |  |  | 2008-04-25 | 2013-08-30 |  |  |  |  |  |  |  |  |  |  |  |  |  |  |  |  |  |  |  |  |  |  |  |  |  |  |  |  |  |  |  |  |  |  |  |  |  |  |  |  |  |  |  |  |  |  |  |  |  |  |  |  |  |  |  |
| 3C-01M |  | Civil A-E Dsgns of H-D Complex & CHL Addition are Comptd. | milestone | 0d | 2008-04-25 A | 2008-04-25 A | 1243040M | 100% | 2008-05-01 | 2008-05-01 |  |  | finish on or before 2007-12-31 |  | 0 | CVL | YASKY R | 2 | 1 | 1 | 3 | C | M | REBECCA Y |  |  |  |  |  |  |  |  |  |  |  |  |  |  |  |  |  |  |  |  |  |  |  |  |  |  |  |  |  |  |  |  |  |  |  |  |  |
| 3C-02M |  | Civil Dsgn Work by Facilt's Management for the Accel projects (does not Include CHL) is Comptd. | milestone | 0d | 2008-09-26 A | 2008-09-26 A | 1241070, 1241150, 1241190, 1241110, 1241030 | 100% | 2008-10-27 | 2008-10-27 |  |  | finish on or before 2008-07-31 |  | 0 | CVL | YASKY R | 2 | 1 | 1 | 3 |  | M | REBECCA Y | 08-052 |  |  |  |  |  |  |  |  |  |  |  |  |  |  |  |  |  |  |  |  |  |  |  |  |  |  |  |  |  |  |  |  |  |  |  |  |
| 3C-04M |  | Civil Constr Contract Award of the CHL Bldng Addition, Doesn't Include the Elect & Cooling Water Utility distrib. | milestone | 0d | 2008-12-19 A | 2008-12-19 A | 1621005 | 100% | 2009-01-06 | 2009-01-06 |  |  | finish on or before 2009-04-30 |  | 0 | CVL | YASKY R | 2 | 1 | 1 | 3 |  | M | REBECCA Y |  |  |  |  |  |  |  |  |  |  |  |  |  |  |  |  |  |  |  |  |  |  |  |  |  |  |  |  |  |  |  |  |  |  |  |  |  |
| 3C-03M |  | Civil Constr Contract Award for P- I of the H-D Complex conventional Facilt's. | milestone | 0d | 2009-01-21 A | 2009-01-21 A | 16331005 | 100% | 2009-03-03 | 2009-03-03 |  |  | finish on or before 2009-04-30 |  | 0 | CVL | YASKY R | 2 | 1 | 1 | 3 |  | M | REBECCA Y |  |  |  |  |  |  |  |  |  |  |  |  |  |  |  |  |  |  |  |  |  |  |  |  |  |  |  |  |  |  |  |  |  |  |  |  |  |
| 3C-06M |  | Civil Sitework & Utility Distrbtn Associated with P- I of the H-D complex Comptd. | milestone | 0d | 2010-10-22 A | 2010-10-22 A | 16331010K FS+25d, 16331010D, 16331010H, 16331010A, 16331010J, 16331010B, 16331010L FS-10d, 16331010, 16331010C, 16331010G, 16331010F | 100% | 2010-11-16 | 2010-11-16 |  |  |  |  | 0 | CVL | YASKY R | 2 | 1 | 1 | 3 |  | M | REBECCA Y |  | 09-044 | 10-061 | 12-015 |  |  |  |  |  |  |  |  |  |  |  |  |  |  |  |  |  |  |  |  |  |  |  |  |  |  |  |  |  |  |  |  |  |
| 3C-11M |  | Civil Constr Electrical Distrbtn Upgrades at the N&S Access Bldngs & at the N&S Linac bldgs Comptd . | milestone | 0d | 2010-10-25 A | 2010-10-25 A | 16122025 | 100% | 2010-11-01 | 2010-11-01 |  |  | finish on or before 2012-04-30 |  | 0 | CVL | YASKY R | 2 | 1 | 1 | 3 |  | M | REBECCA Y |  |  |  |  | 10-033 |  |  |  |  |  |  |  |  |  |  |  |  |  |  |  |  |  |  |  |  |  |  |  |  |  |  |  |  |  |  |  |  |
| 3C-09M |  | Start Installtn, RFE of H-D Cryo Plant Bldng Comptd. | milestone | 0d | 2011-09-30 A | 2011-09-30 A | 16332040F | 100% | 2011-10-27 | 2011-10-27 |  |  | finish on or before 2011-06-30 |  | 0 | CVL | YASKY R | 2 | 1 | 1 | 3 |  | M | REBECCA Y |  |  |  |  |  | 2 | CVL | 08-023 | 10-059 | 11-020 |  |  |  |  |  |  |  |  |  |  |  |  |  |  |  |  |  |  |  |  |  |  |  |  |  |  |  |
| 3C-07M |  | Civil Constr Elect & Cooling Water Utility Distrbtn to Supprt CHL#2 Comptd. | milestone | 0d | 2011-10-12 A | 2011-10-12 A | 16222035M FS-10d | 100% | 2011-11-09 | 2011-11-09 |  |  | finish on or before 2011-06-30 |  | 0 | CVL | YASKY R | 2 | 1 | 1 | 3 |  | M | REBECCA Y |  |  |  |  |  |  |  |  |  |  | 10-021 |  |  |  |  |  |  |  |  |  |  |  |  |  |  |  |  |  |  |  |  |  |  |  |  |  |  |
| 3C-08M |  | Civil Constr N&S Access Bldng Additions & BSW Service bldng Addition Comptd. | milestone | 0d | 2011-12-06 A | 2011-12-06 A | 16113025, 16111025 | 100% | 2012-02-29 | 2012-02-29 |  |  | finish on or before 2012-04-30 |  | 0 | CVL | YASKY R | 2 | 1 | 1 | 3 |  | M | REBECCA Y |  |  |  |  |  |  |  |  |  |  |  |  |  |  |  |  |  |  |  |  |  |  |  |  |  |  |  |  |  |  |  |  |  |  |  |  |  |
| 3C-10M |  | Start Installtn, RFE of Tagger Area portion of the Underground Accel Tunnel Comptd. | milestone | 0d | 2012-01-31 A | 2012-01-31 A | 16332010, 16332030 FS-250d, 16332010U | 100% |  |  |  |  | finish on or before 2011-12-30 |  | 0 | CVL | YASKY R | 2 | 1 | 1 | 3 |  | M | REBECCA Y |  |  |  |  |  |  |  |  | 10-059 |  |  | 11-044 |  |  |  |  |  |  |  |  |  |  |  |  |  |  |  |  |  |  |  |  |  |  |  |  |  |
| 3C-13M |  | Blue Crab End of Occupation | milestone | 0d | 2013-08-30 A | 2013-08-30 A | 197111110, 197111105, 197111085, 197111130, 197111065, 197111145, 197111059 | 100% | 2013-09-03 | 2013-09-03 |  |  | mandatory finish 2013-08-30 |  | 0 |  | YASKY R |  | 1 | 1 | 3 |  | M | REBECCA Y |  |  |  |  |  |  |  |  |  |  |  |  | 10-020 | 11-1VA |  |  |  |  |  |  |  |  |  |  |  |  |  |  |  |  |  |  |  |  |  |  |  |
|  | 1.03P | **1.03P LEVEL 3 PHYSICS MILESTONES** |  |  | 2009-10-30 | 2016-06-24 |  |  |  |  |  |  |  |  |  |  |  |  |  |  |  |  |  |  |  |  |  |  |  |  |  |  |  |  |  |  |  |  |  |  |  |  |  |  |  |  |  |  |  |  |  |  |  |  |  |  |  |  |  |  |  |
| 32-12M |  | H-D Expermntl Equipment Dsgn Comptd | milestone | 0d | 2009-10-30 A | 2009-10-30 A | 12353045M FS+69d, 123221025, 123212035, 123212015, 123211055, 12323039, 12321017, 9-100M FS+22d | 100% | 2009-11-05 | 2009-11-05 |  |  | finish on or before 2009-09-30 |  | 0 |  | YOUNG G |  | 1 | 1 | 3 |  | M | YOUNG G | 08-052 |  |  |  |  |  |  |  |  |  |  |  |  |  | 2008-06-30 | D |  |  |  |  |  |  |  |  |  |  |  |  |  |  |  |  |  |  |  |  |  |
| 3P-23M |  | Hall D Life Safety Systems Operational | milestone | 0d | 2011-09-15 A | 2011-09-15 A | 16332015 FS-20d | 100% | 2011-10-04 | 2011-10-04 |  |  | finish on or before 2011-10-03 |  | 0 |  | YOUNG G |  | 1 | 1 | 3 |  | M | YOUNG G |  |  |  |  |  |  |  |  |  |  |  |  |  |  |  |  | IPL | 09-028 | 09-028 | 11-004 |  |  |  |  |  |  |  |  |  |  |  |  |  |  |  |  |  |
| 3P-03M |  | Start Removl of Expermntl Equipmnt from H-B Prior to major Installtns of New Equipmnt | milestone | 0d | 2012-05-18 A | 2012-05-18 A | 2-02M | 100% | 2012-06-01 | 2012-06-01 |  |  | start on or before 2012-04-30 |  | 0 |  | YOUNG G |  | 1 | 1 | 3 |  | M | YOUNG G |  |  |  |  |  |  |  |  |  |  |  |  |  |  |  |  |  |  |  |  | 11-026 |  |  |  |  |  |  |  |  |  |  |  |  |  |  |  |  |
| 3P-04M |  | Start Removl of Expermntl Equipmnt from H-C Prior to major Installtns of New Equipmnt | milestone | 0d | 2012-05-18 A | 2012-05-18 A | 2-02M | 100% | 2012-06-01 | 2012-06-01 |  |  | start on or before 2012-05-31 |  | 0 |  | YOUNG G |  | 1 | 1 | 3 |  | M | YOUNG G |  |  |  |  |  |  |  |  |  |  |  |  |  |  |  |  |  |  |  |  |  |  |  |  |  |  |  |  |  |  |  |  |  |  |  |  |  |
| 3P-01M |  | Start Expermntl Equipmnt Installtn into H-A | milestone | 0d | 2012-06-11 A | 2012-06-11 A | 14151005 FS-40d, 14152015 FS-80d | 100% | 2012-08-22 | 2012-08-22 |  |  |  |  | 0 |  | YOUNG G |  | 1 | 1 | 3 |  | M | YOUNG G |  |  |  |  |  |  |  |  |  |  |  |  |  |  |  |  |  |  |  |  |  | 10-048 |  |  |  |  |  |  |  |  |  |  |  |  |  |  |  |
| 3P-08M |  | Start Expermntl Equipmnt Installtn into H-B | milestone | 0d | 2012-12-10 A | 2012-12-10 A | 3P-02M, 3P-03M | 100% | 2013-03-04 | 2013-03-04 |  |  |  |  | 0 |  | YOUNG G |  | 1 | 1 | 3 |  | M | YOUNG G |  |  |  |  |  |  |  |  |  |  |  |  |  |  |  |  |  |  |  |  |  |  |  |  |  |  |  |  |  |  |  |  |  |  |  |  |  |
| 3P-24M |  | Start Hall D Cooldown | milestone | 0d | 2012-12-17 A | 2012-12-17 A | 181332000 FS-40d, 13327000 FS-20d, 18241010 FS-20d, 13321050 FS-20d, 13643345 FS-30d | 100% | 2013-01-08 | 2013-01-08 |  |  | start on or before 2012-12-17 |  | 0 |  | YOUNG G |  | 1 | 1 | 3 |  | M | YOUNG G |  |  |  |  |  |  |  |  |  |  |  |  |  |  |  |  | IPL | 09-028 | 09-028 | 11-004 |  |  | 11-036 |  |  |  |  |  |  |  |  |  |  |  |  |  |  |
| 3P-07M |  | Start Expermntl Equipmnt Installtn into H-C | milestone | 0d | 2013-02-01 A | 2013-02-01 A | 14368010M, 2-02M | 100% | 2013-03-01 | 2013-03-01 |  |  | start on or before 2012-05-31 |  | 0 |  | YOUNG G |  | 1 | 1 | 3 |  | M | YOUNG G |  |  |  |  |  |  |  |  |  |  |  |  |  |  |  |  |  |  |  |  |  |  |  | 11-046 | 12-012 | 12-036F | 13-006F | XX |  |  |  |  |  |  |  |  |  |
| 3P-02M |  | Removl of Expermntl Equipmnt Prior to major Installtns of New Equipmnt in H-B is Comptd. | milestone | 0d | 2013-02-11 A | 2013-02-11 A | 3P-03M, 14264002M, 2-02M | 100% | 2013-03-01 | 2013-03-01 |  |  |  |  | 0 |  | YOUNG G |  | 1 | 1 | 3 |  | M | YOUNG G |  |  |  |  |  |  |  |  |  |  |  |  |  |  |  |  |  |  |  |  | 11-026 |  |  |  |  |  |  | XX |  |  |  |  |  |  |  |  |  |
| 3P-12M |  | Start E-B Commssng of H-A Detctr's, Electrnc's, & BL Devices | milestone | 0d | 2014-02-26 | 2014-02-26 | 2811019, 2-03M FS+40d |  |  |  | 21d | 0d | start on or after 2014-02-01 | 8/5 M-F w/JLAB Holidays ReBaseline | 0 |  | YOUNG G |  | 1 | 1 | 3 |  | M | YOUNG G |  |  |  |  |  |  |  |  |  |  |  |  |  |  |  |  |  |  |  |  | 11-026 |  |  |  |  |  |  |  | 12-025 | PR |  |  |  |  |  |  |  |
| 3P-25M |  | 10 GeV Beam to Hall D Tagger | milestone | 0d | 2014-03-21 | 2014-03-21 | 3A-49M, 4A-12M, 23641100, 3P-12M, 23641085, 3A-53M |  |  |  | 16d | 254d | finish on or before 2014-04-14 | 8/5 M-F w/JLAB Holidays ReBaseline | 0 |  | YOUNG G |  | 1 | 1 | 3 |  | M | YOUNG G |  |  |  |  |  |  |  |  |  |  |  |  |  |  |  |  | IPL | 09-028 | 09-028 | 11-004 |  |  | 11-036 |  |  |  |  |  |  | PR | 3P-25M |  |  |  |  |  |  |
| 3P-16M |  | Start E-B Commssng of H-D Detctr's, Electrnc's, & BL Devices | milestone | 0d | 2014-11-19 | 2014-11-19 | 2-12M, 2811064, 23611065M, 23614045M, 2-25M FS-120d, 2-03M FS+100d, 13611065M, 1562180 |  |  |  | 8d | 0d | start on or after 2014-04-01 | 8/5 M-F w/JLAB Holidays ReBaseline | 0 |  | YOUNG G |  | 1 | 1 | 3 |  | M | YOUNG G |  |  |  |  |  |  |  |  |  |  |  |  |  |  |  | D |  | 09-028 |  |  | 11-026 |  |  |  |  |  |  |  |  | PR |  | 1 | 11-006 | 12-021 |  |  |  |
| 3P-26M |  | Torus Assembled and Tested | milestone | 0d | 2015-09-21 | 2015-09-21 | 24264788M |  |  |  | 25d | 0d |  | 8/5 M-F w/JLAB Holidays ReBaseline | 0 |  | YOUNG G |  | 1 | 1 | 3 |  | M | YOUNG G |  |  |  |  |  |  |  |  |  |  |  |  |  |  |  |  | IPL | 09-028 | 09-028 | 11-004 |  |  | 11-036 |  |  |  |  |  |  | PR | 3P-26M |  |  |  |  |  |  |
| 3P-18M |  | Start E-B Commssng of H-C Detctr's, Electrnc's, & BL Devices | milestone | 0d | 2016-02-02 | 2016-02-02 | 2-25M, 2-03M, 24368500, 2811049 |  |  |  | 38d | 0d | start on or after 2014-09-01 | 8/5 M-F w/JLAB Holidays ReBaseline | 0 |  | YOUNG G |  | 1 | 1 | 3 |  | M | YOUNG G |  |  |  |  |  |  |  |  |  |  |  |  |  |  |  |  |  | 09-028 |  |  | 11-026 |  |  |  | 12-012 | 12-036 |  |  |  | PR |  |  |  |  | 10-069 | 12-054 |  |
| 3P-22M |  | E-B Commssng of H-C Detctr's, Electrnc's, & BL Devices Comptd | milestone | 0d | 2016-02-08 | 2016-02-08 | 2823X000, 2811050, 2812035 |  |  |  | 42d | 0d |  |  | 0 |  | YOUNG G |  | 1 | 1 | 3 |  | M | YOUNG G |  |  |  |  |  |  |  |  |  |  |  |  |  |  |  |  | IPL | 09-028 |  |  | 11-026 |  |  |  | 12-012 | 12-036 |  |  |  | PR |  |  |  |  |  | 12-054 |  |
| 3P-20M |  | Start E-B Commssng of H-B Detctr's, Electrnc's, & BL Devices | milestone | 0d | 2016-06-13 | 2016-06-13 | 2-03M, 2811034, 2-25M |  |  |  | -60d | 0d | start on or after 2014-10-01 | 8/5 M-F w/JLAB Holidays ReBaseline | 0 |  | YOUNG G |  | 1 | 1 | 3 |  | M | YOUNG G |  |  |  |  |  |  |  |  |  |  |  |  |  |  |  |  |  |  |  |  | 11-026 |  |  |  |  |  |  |  |  | PR |  |  |  |  |  |  | 12-024 |
| 3P-21M |  | E-B Commssng of H-B Detctr's, Electrnc's, & BL Devices Comptd | milestone | 0d | 2016-06-24 | 2016-06-24 | 14234020LOE, 2811035, 2812020, 2822X000 |  |  |  | -55d | 0d |  |  | 0 |  | YOUNG G |  | 1 | 1 | 3 |  | M | YOUNG G |  |  |  |  |  |  |  |  |  |  |  |  |  |  |  |  | IPL | 09-028 |  |  | 11-026 |  |  |  |  |  |  |  |  | PR |  |  |  |  |  |  | 12-024 |

Notes:
- 3C-02M: Scope: Design / work by Facilities Management for the Accelerator projects (does not include / CHL) is complete.
- 3C-04M: Scope: Construction / contract award of the CHL building addition. D oesn't include the elect and cooling / water utility distrib.
- 3C-03M: Scope: The / construction contract award for Phase I of the Hall D Complex conventional / facilities. Phase I includes / Experimental Hall D, Counting House foundation for structural support of Hall D, / and preliminary sitework and utilities.
- 3C-06M: Scope: Complete / the sitework and utility distribution associated with Phase I of the Hall D / complex. Includes clearing trees, / contractor mobilization, and electrical distribution to Experimental Hall / D.
- 3C-11M: Scope: Construction / completion of the electrical distribution upgrades at the N&S Access / buildings and at the N&S Linac bldgs.
- 3C-09M: Scope: Civil / construction completion of Hall D Cryo Plant Building and ready for equipment / installation to start.
- 3C-07M: Scope: The / construction completion of the electrical and cooling water utility distribution / to support CHL#2.
- 3C-08M: Scope: Civil / construction completion of the North and South Access building additions and the / BSW Service building addition.
- 3C-10M: Scope: Civil / constr completion of the Tagger area portion of the underground Accel tunnel / and RFE installation to start.
- 32-12M: Scope: Completion of experimental equipment designs for Hall / D / Made level 3 from / level 2 4/11/07 RKC
- 3P-23M: Scope: Complete electron beam commissioning / of Hall C detectors, electronics, and beamline devices / Explanation: IPL from 6 GeV 5333065, 5333070 and 5333075 / Added FY14 Funding Predeccessor with 57.6 weeks lag to bring start date out / to match 6 GeV impact
- 3P-03M: Scope: Begin removal of experimental / equipment from Hall B prior to major installations of new / equipment
- 3P-04M: Scope: Begin removal of experimental / equipment from Hall C prior to major installations of new / equipment
- 3P-01M: Scope: Begin experimental equipment / installation into Hall A
- 3P-08M: Scope: Begin experimental equipment / installation into Hall B
- 3P-24M: Scope: Complete electron beam commissioning / of Hall C detectors, electronics, and beamline devices / Explanation: IPL from 6 GeV 5333065, 5333070 and 5333075 / Added FY14 Funding Predeccessor with 57.6 weeks lag to bring start date out / to match 6 GeV impact
- 3P-07M: Scope: Begin experimental equipment / installation into Hall C
- 3P-02M: Scope: Removal of experimental equipment / prior to major installations of new equipment in Hall B is / complete.
- 3P-12M: Scope: Begin electron beam commissioning of / Hall A detectors, electronics, and beamline devices
- 3P-25M: Scope: Complete electron beam commissioning / of Hall C detectors, electronics, and beamline devices / Explanation: IPL from 6 GeV 5333065, 5333070 and 5333075 / Added FY14 Funding Predeccessor with 57.6 weeks lag to bring start date out / to match 6 GeV impact
- 3P-16M: Scope: Begin electron beam commissioning of / Hall D detectors, electronics, and beamline devices
- 3P-26M: Scope: Complete electron beam commissioning / of Hall C detectors, electronics, and beamline devices / Explanation: IPL from 6 GeV 5333065, 5333070 and 5333075 / Added FY14 Funding Predeccessor with 57.6 weeks lag to bring start date out / to match 6 GeV impact
- 3P-18M: Scope: Begin electron beam commissioning of / Hall C detectors, electronics, and beamline devices
- 3P-22M: Scope: Complete electron beam commissioning / of Hall C detectors, electronics, and beamline devices
- 3P-20M: Scope: Begin electron beam commissioning of / Hall B detectors, electronics, and beamline devices
- 3P-21M: Scope: Complete electron beam commissioning / of Hall B detectors, electronics, and beamline devices

| ID | WBS | Activity | Type | Duration | Start | Finish | Predecessors | Complete | Planned start | Planned finish | Total float | Free float | Constraint | Calendar | Planned FinishUDF | MONTHLY EV COST | RESP - Responsibility | STRT%COMP for CM EVM | FNSH%COMP for CM EVM | Milestone Level | EVMS Reporting Codes | CAM RESPONSIBLE | GROP Group | MILE - Milestone | CR 07-015 | CR 07-024 | Profile change | 12 GeV 5th level Critical Path | CR 07-033 | CR 08-002 | Inter Project Link (IPL) | CR 08-048 | CR 10-030 | CR 10-028 | CR 10-031 | CR 10-064 | CR 10-066 | CR 12-025 | Post Rebaseline | CR 10-070 | CR 12-018 | CR 12-028 | CR 12-029 | CR 10-065 | CR 11-026 | CR 12-037 | Original Activity ID Rebaseline | CR 12-026 | CR 12-050 |
| --- | --- | --- | --- | --- | --- | --- | --- | --- | --- | --- | --- | --- | --- | --- | --- | --- | --- | --- | --- | --- | --- | --- | --- | --- | --- | --- | --- | --- | --- | --- | --- | --- | --- | --- | --- | --- | --- | --- | --- | --- | --- | --- | --- | --- | --- | --- | --- | --- | --- |
|  | 1.03R | **1.03R LEVEL 3 REVIEW MILESTONES** |  |  | 2006-06-27 | 2009-10-30 |  |  |  |  |  |  |  |  |  |  |  |  |  |  |  |  |  |  |  |  |  |  |  |  |  |  |  |  |  |  |  |  |  |  |  |  |  |  |  |  |  |  |  |
| 3R-1M |  | FY06 Lehman Review | milestone | 0d | 2006-06-27 A | 2006-06-27 A |  | 100% |  |  |  |  |  |  | 2006-06-27 | 0 | RODE C | 1 | 1 | 3 | N/A | CLAUS R |  |  |  |  |  |  |  |  |  |  |  |  |  |  |  |  |  |  |  |  |  |  |  |  |  |  |  |
| 3R-2M |  | CD-2 Review IPR | milestone | 0d | 2007-06-28 A | 2007-06-28 A | 11111000M, 121411015M, 2-20M, 2-21M, 2-19M | 100% | 2007-06-29 | 2007-06-29 |  |  | mandatory finish 2007-06-29 |  | 2007-06-29 | 0 | DOE | 1 | 1 | 3 | N/A | CLAUS R | CDS | 0 | 07-015 |  |  |  |  |  |  |  |  |  |  |  |  |  |  |  |  |  |  |  |  |  |  |  |  |
| 3R-3M |  | CD-2 Review EIR | milestone | 0d | 2007-08-14 A | 2007-08-14 A | 1212121130M, 3R-2M | 100% | 2007-10-01 | 2007-10-01 |  |  | mandatory finish 2007-08-15 |  | 2007-08-15 | 0 | DOE | 1 | 1 | 3 | N/A | CLAUS R | CDS | 0 |  |  |  |  |  |  |  |  |  |  |  |  |  |  |  |  |  |  |  |  |  |  |  |  |  |
| 3R-07M |  | EVMS Assessment | milestone | 0d | 2007-10-01 A | 2007-10-01 A | 3R-2M | 100% | 2007-11-01 | 2007-11-01 |  |  | mandatory start 2007-09-17 |  |  | 0 | RODE C | 1 | 1 | 3 | N/A | CLAUS R |  |  |  | 07-024 | C |  |  |  |  |  |  |  |  |  |  |  |  |  |  |  |  |  |  |  |  |  |  |
| 3R-05M |  | CD-3 Review IPR | milestone | 0d | 2008-07-23 A | 2008-07-23 A | 1132865M FS-45d, 1112015M, 12131.10010, 3C-01M, 1132875M FS-45d, 11111005RKC, 1141005RKC5, 121613027, 1141005RKC, 1251006RKC, 121111010M, 1152001RKC, 12167027, 19001RKC, 1152040, 1155001RKC, 1132800M FS-45d, 1132841 FS-45d, 1132021RKC, 12131.04020, 121611041, 12162027, 1154001RKC, 1132890M FS-45d, 1132831M FS-45d, 12131.11010, 12165027, 121612022, 2-05M, 19005RKC, 1242040M, 12131.03010, 121614027, 1212111170, 2-23M, 1152005A, 2-24M | 100% | 2008-08-01 | 2008-08-01 |  |  | mandatory finish 2008-07-31 |  |  | 0 | RODE C | 1 | 1 | 3 | M | CLAUS R |  |  |  | 07-024 | C | 5 |  |  |  |  |  |  |  |  |  |  |  |  |  |  |  |  |  |  |  |  |  |
| 3R-08M |  | OECM EVMS Contractor CERTIFICATION Completed | milestone | 0d | 2008-09-19 A | 2008-09-19 A | 2-22M FS+167d | 100% | 2008-10-01 | 2008-10-01 |  |  | finish on or before 2008-06-30 |  |  | 0 | RODE C | 1 | 1 | 3 | M | CLAUS R |  |  |  |  |  |  | 07-033 | 08-002 |  |  |  |  |  |  |  |  |  |  |  |  |  |  |  |  |  |  |  |
| 3R-06M |  | PED Complete (30 Sep 09) (IPL) | milestone | 0d | 2009-10-30 A | 2009-10-30 A | 12232020, 12236025, 122152020, 12222065, 12222015M, 1241176M, 12361010, 12323040M, 12321018M, 1211020M5, 121114010M, 12131.07015b, 12131.03020, 12131.09000, 121642010A, 121641110M, 1212123050, 1212127065M, 121414016, 122323015, 14315055x, 12236010b, 12226010a, 12223040M, 12351055M, 1234060, 12156035, 12131.07015, 121643140, 121643010A, 12162040M, 1212125025M, 1212122170, 1212126170, 121221150, 121416010, 121414020a, 121414015a, 121456999, 122325020, 122312045b, 12236830LOE, 12226020a, 12224005, 1211020M10, 1211020M15, 12156002, 121642015A, 121612030, 121612035, 1212121170, 1212121145M, 1212113170, 121224999, 121434999, 12232015, 122322015b, 12225040, 12222080, 1222223041M, 1222223040, 1233040M, 1211020M, 12156040M, 121641170, 12236020, 12225045, 12225050, 12222055b, 12222060, 12222055, 126080M, 12361005, 12353045M, 1234180M, 1234055, 121113005, 121114005, 12131.04025, 121324000, 121322000, 12167028, 121643045A, 121613040M, 12166035, 1212121095, 1212124170, 1212112145M, 121411110M, 121446999, 121454015a, 121425015, 12225020, 1222232030, 12222015a, 12222045, 1233039, 12131.08000, 121323000, 121642170, 121643065A, 1212123055M, 1212112020, 122324015, 122153010, 12221050M, 1222241035M, 12222035M, 12222015, 12222070, 1241035M, 12322018M, 121325000, 121643170, 121643080A, 12163050M, 12163170, 121416005a, 122311055a, 12236015b, 12226015a, 12222000a, 123231030, 123221908LOE, 121138060, 12156045, 12165030, 12165035, 121611055M, 121614035M, 1212123170, 1212127170, 1212127060, 1212122110M, 121223060a, 121416005, 121414020, 32-12M | 100% | 2009-11-02 | 2009-11-02 |  |  | mandatory finish 2009-10-30 |  |  | 0 | RODE C | 1 | 1 | 3 | M | CLAUS R |  |  |  |  | C |  |  |  | IPL |  |  |  |  |  |  |  |  |  |  |  |  |  |  |  |  |  |  |
|  | 1.04A | **1.04A LEVEL 4 ACCELERATOR MILESTONES** |  |  | 2011-06-01 | 2014-03-21 |  |  |  |  |  |  |  |  |  |  |  |  |  |  |  |  |  |  |  |  |  |  |  |  |  |  |  |  |  |  |  |  |  |  |  |  |  |  |  |  |  |  |  |
| 4A-01M |  | Start Precurser Maint Down (6 mo dur?, ~1 yr before Installtn Down?) (IPL) | milestone | 0d | 2011-06-01 A | 2011-06-01 A | 13451105a, 13421095, 13421046a, 13421090, 13421046ab, 13421046b, 13427180, 13434007, 13427063LOE, 13427055, 13433015, 13427180a | 100% | 2011-07-01 | 2011-07-01 |  |  | mandatory start 2011-05-13 |  |  | 0 | HARWOOD L | 1 | 1 | 4 | M | LEIGH H |  |  |  |  |  |  |  |  | IPL | 08-048 | 10-030 |  |  |  |  |  |  |  |  |  |  |  |  |  |  |  |  |
| 4A-03M |  | Start HPA Installtn | milestone | 0d | 2011-06-01 A | 2011-06-01 A | 1321122050, 3A-01M | 100% | 2011-07-18 | 2011-07-18 |  |  |  |  |  | 0 | HARWOOD L | 1 | 1 | 4 | M | LEIGH H | ACCL | 4 |  |  |  |  |  |  |  | 08-048 |  | 10-028 | 10-031 | 10-064 | 10-066 |  |  |  |  |  |  |  |  |  |  |  |  |
| 4A-04M |  | End of Precurser Maint Down (6 mo dur?, ~1 yr before Installtn Down?) | milestone | 0d | 2011-11-14 A | 2011-11-14 A | 14368171, 13427115M, 131502005a FS+15d, 14368170, 13427062LOE, 13427060, 13221093, 13221093a, 14341007, 13436035 | 100% | 2011-12-01 | 2011-12-01 |  |  | mandatory finish 2011-11-11 |  |  | 0 | HARWOOD L | 1 | 1 | 4 | M | LEIGH H |  |  |  |  |  |  |  |  |  | 08-048 |  |  |  |  |  |  |  |  |  |  |  |  |  |  |  |  |  |
| 4A-10M |  | Start Accel Hot Chkout | milestone | 0d | 2013-10-14 A | 2013-10-14 A | 3A-04M, 3A-41M, 1351080, 1363025b, 1367025a, 23224100 FS-40d, 13454050, 1353095, 1363025a, 2367055 FS-40d, 23454055b FS-20d, 3A-40M, 23213020M FS-45d, 3A-54M FS-30d, 3A-52M, 4A-09M FS-20d, 13221097LOE, 1363025, 13642030M, 1367025, 3C-11M, 3A-58M FS-1d, 13213020M, 23224100a FS-40d, 3A-47M FS-20d, 13454055, 1366030M, 3A-56M, 3A-10M, 13224100, 1352035, 13612035M, 23454055 FS-20d, 13221095, 1363014a, 13643185M, 1367055 | 100% | 2013-11-01 | 2013-11-01 |  |  |  |  |  | 0 | HARWOOD L | 1 | 1 | 4 | M | LEIGH H | ACCL | 4 |  |  |  |  |  |  | IPL | 08-048 |  |  |  |  |  | 12-025 | PR |  |  |  |  |  |  |  |  |  |  |
| 4A-07M |  | Linac Installtn Comptd | milestone | 0d | 2013-11-20 | 2013-11-20 | 1331.02080, 1331.02066, 3A-47M, 181331000, 3A-41M, 1331.11000, 2331.1005, 1331.1005 |  |  |  | 26d | 5d |  |  |  | 0 | HARWOOD L | 1 | 1 | 4 | M | LEIGH H | ACCL | 4 |  |  |  |  |  |  |  | 08-048 |  |  |  |  | 10-066 |  | PR | 10-070 | 12-018 | 12-028 | 12-029F |  |  |  |  |  |  |
| 4A-08M |  | Accelerator Beam Transport Comptd | milestone | 0d | 2013-11-27 | 2013-11-27 | 3A-52M, 3A-56M, 3A-46M, 3A-44M, 3A-54M, 3A-43M |  |  |  | 21d | 0d |  |  |  | 0 | HARWOOD L | 1 | 1 | 4 | M | LEIGH H | ACCL | 4 |  |  |  |  |  |  |  | 08-048 |  |  |  |  |  |  | PR |  | 12-018F |  | 12-029F | 10-065 |  |  |  |  |  |
| 4A-09M |  | I&C/Sfty for Accelerator Installtn Comptd | milestone | 0d | 2013-11-27 | 2013-11-27 | 2365065M, 23643170M, 23612035M, 23613035M |  |  |  | 21d | 0d |  |  |  | 0 | HARWOOD L | 1 | 1 | 4 | M | LEIGH H | ACCL | 4 |  |  |  |  |  |  |  | 08-048 |  |  |  |  |  |  | PR |  | 12-018F |  |  | 10-065 | 11-026 | 12-037 |  |  |  |
| 4A-11M |  | Beam Transport to Halls Comptd | milestone | 0d | 2014-02-28 | 2014-02-28 | 3A-44M, 3A-53M, 3A-42M, 3A-43M, 3A-46M |  |  |  | 58d | 45d |  | 8/5 M-F w/JLAB Holidays ReBaseline |  | 0 | HARWOOD L | 1 | 1 | 4 | M | LEIGH H | ACCL | 4 |  |  |  |  |  |  |  |  |  |  |  |  |  |  | PR |  | 12-018F |  | 12-029F | 10-065 |  |  | 4A-11M | 12-026 |  |
| 4A-06M |  | Pwr (Mag) Installtn Comptd | milestone | 0d | 2014-03-07 | 2014-03-07 | 2-25M FS-180d, 3A-48M |  |  |  | 13d | 0d |  |  |  | 0 | HARWOOD L | 1 | 1 | 4 | M | LEIGH H | ACCL | 4 |  |  |  |  |  |  |  | 08-048 |  | 10-028 |  |  |  |  | PR |  | 12-018F |  | 12-029 |  |  |  |  |  | 12-050 |
| 4A-12M |  | I&C/Sfty Installtn Comptd | milestone | 0d | 2014-03-21 | 2014-03-21 | 23643185M, 23643280, 2365035M, 23641100M, 23642030M, 2-25M FS-120d |  |  |  | 16d | 0d |  | 8/5 M-F w/JLAB Holidays ReBaseline |  | 0 | HARWOOD L | 1 | 1 | 4 | M | LEIGH H | ACCL | 4 |  |  |  |  |  |  |  |  |  |  |  |  |  |  | PR |  | 12-018F |  |  | 10-065 | 11-026 | 12-037 | 4A-12M |  |  |
|  | 1.04P | **1.04P Level 4 PHYSICS MILESTONE** |  |  |  |  |  |  |  |  |  |  |  |  |  |  |  |  |  |  |  |  |  |  |  |  |  |  |  |  |  |  |  |  |  |  |  |  |  |  |  |  |  |  |  |  |  |  |  |
|  | 1.09FA | **1.09FA LEVEL 9 FUNDING AVAILABLE MILESTONES** |  |  | 2006-10-02 | 2014-10-01 |  |  |  |  |  |  |  |  |  |  |  |  |  |  |  |  |  |  |  |  |  |  |  |  |  |  |  |  |  |  |  |  |  |  |  |  |  |  |  |  |  |  |  |
| 9-070M |  | FY07 Funds Available | milestone | 0d | 2006-10-02 A | 2006-10-02 A |  | 100% |  |  |  |  | mandatory start 2006-10-01 |  | 2006-10-02 | 0 | RODE C | 1 | 1 | 9 | N/A | CLAUS R |  |  |  |  |  |  |  |  |  |  |  |  |  |  |  |  |  |  |  |  |  |  |  |  |  |  |  |
| 9-080M |  | FY08 Funds Available | milestone | 0d | 2007-10-01 A | 2007-10-01 A | 9-070M | 100% | 2007-11-01 | 2007-11-01 |  |  | mandatory start 2007-10-01 |  |  | 0 | RODE C | 1 | 1 | 9 | N/A | CLAUS R |  |  |  |  |  |  |  |  |  |  |  |  |  |  |  |  |  |  |  |  |  |  |  |  |  |  |  |
| 9-090M |  | FY09 Funds Available | milestone | 0d | 2008-10-01 A | 2008-10-01 A | 9-080M | 100% |  |  |  |  | mandatory start 2008-10-01 |  |  | 0 | RODE C | 1 | 1 | 9 | M | CLAUS R |  |  |  |  |  |  |  |  |  |  |  |  |  |  |  |  |  |  |  |  |  |  |  |  |  |  |  |
| 9-150M |  | End of R&D Funds | milestone | 0d | 2008-11-03 A | 2008-11-03 A | 1152030, 1155030, 1154025, 1135025, 1155010A, 1154060, 1154045, 1154050, 1132897, 1132851M, 1152035, 1155005A, 1132800M, 1132900, 1141005RKC5, 1155020, 1132831M, 1132895, 1141015, 1154040, 1132865M, 1132875M, 1114010, 1141011, 1152040, 1132890M, 11114070M, 1154055, 117908LOE, 1142030, 1141005RKC | 100% |  |  |  |  | mandatory start 2008-10-01 |  |  | 0 | RODE C | 1 | 1 | 9 | M | CLAUS R |  |  |  |  |  |  |  |  |  |  |  |  |  |  |  |  |  |  |  |  |  |  |  |  |  |  |  |
| 9-100M |  | FY10 Funds Available | milestone | 0d | 2009-10-01 A | 2009-10-01 A | 14312010a, 15221190, 15221012A, 15221310, 14312002, 14312010, 14312011, 15221185, 15221191 | 100% | 2009-11-02 | 2009-11-02 |  |  | mandatory start 2009-10-01 |  |  | 0 | RODE C | 1 | 1 | 9 | M | CLAUS R |  |  |  |  |  |  |  |  |  |  |  |  |  |  |  |  |  |  |  |  |  |  |  |  |  |  |  |
| 9-110M |  | FY11 Funds Available | milestone | 0d | 2010-10-01 A | 2010-10-01 A | 16331017, 15222110, 15212070, 15212075, 16223008, 15222025 | 100% | 2010-11-01 | 2010-11-01 |  |  | mandatory start 2010-10-01 |  |  | 0 | RODE C | 1 | 1 | 9 | M | CLAUS R |  |  |  |  |  |  |  |  |  |  |  |  |  |  |  |  |  |  |  |  |  |  |  |  |  |  |  |
| 9-120M |  | FY12 Funds Available | milestone | 0d | 2011-10-01 A | 2011-10-01 A | 1563030, 13322006, 13324010, 13323010, 13326005, 142213133a, 142211020a, 13221010J, 13325005, 142211010a, 13322005, 1316010 | 100% | 2011-11-01 | 2011-11-01 |  |  | mandatory start 2011-10-01 |  |  | 0 | RODE C | 1 | 1 | 9 | M | CLAUS R |  |  |  |  |  |  |  |  |  |  |  |  |  |  |  |  |  |  |  |  |  |  |  |  |  |  |  |
| 9-130M |  | FY13 Funds Available | milestone | 0d | 2012-10-01 A | 2012-10-01 A | 14211085, 13221021, 1321122210, 132121060f, 1563025, 14312034, 13463012, 13422065, 13221026, 132127040, 1563006, 14212025, 13221021A, 1563016, 14324003a, 13414028, 13222061, 13223035A, 1563011, 1563017a, 14212005sA, 13221125A, 14212012E, 14211012E, 14321900a, 132122020f | 100% | 2012-11-01 | 2012-11-01 |  |  | mandatory start 2012-10-01 |  |  | 0 | RODE C | 1 | 1 | 9 | M | CLAUS R |  |  |  |  |  |  |  |  |  |  |  |  |  |  |  |  |  |  |  |  |  |  |  |  |  |  |  |
| 9-140M |  | FY14 Funds Available | milestone | 0d | 2013-10-01 A | 2013-10-01 A |  | 100% | 2013-11-01 | 2013-11-01 |  |  | mandatory start 2013-10-01 |  |  | 0 | RODE C | 1 | 1 | 9 | M | CLAUS R |  |  |  |  |  |  |  |  |  |  |  |  |  |  |  |  | PR |  |  |  |  |  |  |  |  |  |  |
| 9-155M |  | FY15 Funds Available | milestone | 0d | 2014-10-01 | 2014-10-01 |  |  |  |  | 0d |  | mandatory start 2014-10-01 |  |  | 0 | RODE C | 1 | 1 | 9 | M | CLAUS R |  |  |  |  |  |  |  |  |  |  |  |  |  |  |  |  | PR |  |  |  |  |  |  |  |  |  |  |

| ID | WBS | Activity | Type | Duration | Start | Finish | Predecessors | Complete | Planned start | Planned finish | Constraint | Resources | Cost | Remaining Material Cost Based on % Compl | Claimed Material Cost Based on % Complet | Initial Claimed Material Calc | Claimed Material Divider | Calculated Remaining Total Cost | MONTHLY EV COST | RESP - Responsibility | Special | STRT%COMP for CM EVM | FNSH%COMP for CM EVM | EVMS Reporting Codes | CAM RESPONSIBLE | CR 09-012 | Planned FinishUDF | ReBaseline Actuals Adjustment | Milestone Level |
| --- | --- | --- | --- | --- | --- | --- | --- | --- | --- | --- | --- | --- | --- | --- | --- | --- | --- | --- | --- | --- | --- | --- | --- | --- | --- | --- | --- | --- | --- |
|  | 0 | **1.0 CONCEPTUAL & ADVANCED CONCEPTUAL DESIGN REVIEW ACTIVITIES** |  |  | 2006-10-02 | 2013-08-30 |  |  |  |  |  |  |  |  |  |  |  |  |  |  |  |  |  |  |  |  |  |  |  |
| 19001 |  | FY06 Obligations RKC (Oct-Dec 06) |  | 80d | 2006-10-02 A | 2007-02-01 A | 9-070M | 100% |  |  | finish on 2006-12-22 | PLABOR; PROCUREMENT<$50K 60 | 6,839 | 0 | 17000 | 1700000 | 100 | 0 | 6839 | PARKINSON J | LR | 1 | 1 | N/A | CLAUS R | 09-012 |  |  |  |
| 19002RKC |  | FY06 Obligations Exp over $50k RKC (Oct-Dec 06) |  | 80d | 2006-10-02 A | 2007-02-01 A | 9-070M | 100% |  |  | finish on 2006-12-22 | EXPENSES >$50 69 | -2,716 |  |  |  |  |  |  | PARKINSON J | LR | 1 | 1 | N/A | CLAUS R |  |  |  |  |
| 19001RKC |  | FY06 Obligations RKC (Jan-Sep 06) |  | 212d | 2007-01-02 A | 2007-10-31 A | 19001 | 100% |  |  | mandatory start 2007-01-02 | SUPPLIES & MATERIALS; PLABOR; PROCUREMENT<$50K 60 | 341,960 | 0 | 30000 | 3000000 | 100 | 0 | 341960 | PARKINSON J | LR | 1 | 1 | N/A | CLAUS R | 09-012 |  |  |  |
| 19005RKC |  | FY06 Obligations Exp over $50k RKC (Jan-Sep 06) |  | 212d | 2007-01-02 A | 2007-10-31 A | 19002RKC | 100% |  |  | mandatory start 2007-01-02 | EXPENSES >$50 69 | 136,228 |  |  |  |  | 0 | 136228 | PARKINSON J | LR | 1 | 1 | N/A | CLAUS R |  | 2007-09-28 |  |  |
| 19010 |  | Re-Baseline Actuals Adjustment |  | 1d | 2013-08-30 A | 2013-08-30 A |  | 100% | 2013-09-03 | 2013-09-03 |  | PROCUREMENT>$50K 69 NO ESCALATION | -32,159.42 |  |  |  | 100 |  |  |  |  |  |  |  |  |  |  | ADJ |  |
|  | 1 | **1.0.1 ACCELERATOR SYSTEMS** |  |  |  |  |  |  |  |  |  |  |  |  |  |  |  |  |  |  |  |  |  |  |  |  |  |  |  |
|  | 1 | **1.0.1.1 CRYOMODULES** |  |  |  |  |  |  |  |  |  |  |  |  |  |  |  |  |  |  |  |  |  |  |  |  |  |  |  |
|  | 2 | **1.0.1.2 POWER SYSTEMS** |  |  |  |  |  |  |  |  |  |  |  |  |  |  |  |  |  |  |  |  |  |  |  |  |  |  |  |
|  | 3 | **1.0.1.3 CRYOGENICS** |  |  |  |  |  |  |  |  |  |  |  |  |  |  |  |  |  |  |  |  |  |  |  |  |  |  |  |
|  | 4 | **1.0.1.4 BEAM TRANSPORT** |  |  |  |  |  |  |  |  |  |  |  |  |  |  |  |  |  |  |  |  |  |  |  |  |  |  |  |
|  | 5 | **1.0.1.5 EXTRACTION** |  |  |  |  |  |  |  |  |  |  |  |  |  |  |  |  |  |  |  |  |  |  |  |  |  |  |  |
|  | 6 | **1.0.1.6 INSTRUMENTATION, CONTROLS, & SAFETY SYSTEMS** |  |  |  |  |  |  |  |  |  |  |  |  |  |  |  |  |  |  |  |  |  |  |  |  |  |  |  |
|  | 2 | **1.0.2 HALLS A. B, & C** |  |  |  |  |  |  |  |  |  |  |  |  |  |  |  |  |  |  |  |  |  |  |  |  |  |  |  |
|  | 1 | **1.0.2.1 HALL A** |  |  |  |  |  |  |  |  |  |  |  |  |  |  |  |  |  |  |  |  |  |  |  |  |  |  |  |
|  | 2 | **1.0.2.2 HALL B** |  |  |  |  |  |  |  |  |  |  |  |  |  |  |  |  |  |  |  |  |  |  |  |  |  |  |  |
|  | 3 | **1.0.2.3 HALL C** |  |  |  |  |  |  |  |  |  |  |  |  |  |  |  |  |  |  |  |  |  |  |  |  |  |  |  |
|  | 3 | **1.0.3 HALL D** |  |  |  |  |  |  |  |  |  |  |  |  |  |  |  |  |  |  |  |  |  |  |  |  |  |  |  |
|  | 4 | **1.0.4 CIVIL** |  |  |  |  |  |  |  |  |  |  |  |  |  |  |  |  |  |  |  |  |  |  |  |  |  |  |  |
|  | 1 | **1.1 R&D** |  |  | 2006-10-02 | 2013-08-30 |  |  |  |  |  |  |  |  |  |  |  |  |  |  |  |  |  |  |  |  |  |  |  |
|  | 1 | **1.1.1 ACCELERATOR SYSTEMS** |  |  | 2006-10-02 | 2013-08-30 |  |  |  |  |  |  |  |  |  |  |  |  |  |  |  |  |  |  |  |  |  |  |  |
|  | 1 | **1.1.1.1 CRYOMODULES** |  |  | 2006-10-02 | 2013-08-30 |  |  |  |  |  |  |  |  |  |  |  |  |  |  |  |  |  |  |  |  |  |  |  |
|  | 1 | **1.1.1.1.1 FY06/07 R&D Plan** |  |  | 2006-10-02 | 2007-04-20 |  |  |  |  |  |  |  |  |  |  |  |  |  |  |  |  |  |  |  |  |  |  |  |
| 11111005RKC |  | FY06 Obligations RKC |  | 135d | 2006-10-02 A | 2007-04-20 A | 9-070M | 100% |  |  |  | SUPPLIES & MATERIALS; PLABOR | 56,267.74 |  |  |  |  | 0 | 56267.74 | PARKINSON J | LR | 1 | 1 | N/A | JOHN H |  | 2007-03-30 |  |  |
| 11111000M |  | 12 GeV R&D & CDs (Finish 1 Month Later) (R&D PLAN) | milestone | 0d | 2007-02-28 A | 2007-02-28 A | 111123015 | 100% | 2007-04-11 | 2007-04-11 |  |  |  |  |  |  |  |  | 0 | HOGAN J |  | 1 | 1 | N/A | JOHN H |  | 2007-03-15 |  | 9 |

Notes:
- 19001: Current Status: Added FY06 Obligations used Travel / for EDP and combined Purch/Serv/Labor/Consult into one number.
- 19002RKC: Current Status: Added FY06 Obligations used Travel / for EDP and combined Purch/Serv/Labor/Consult into one number.
- 19001RKC: Current Status: Added FY06 Obligations used Travel / for EDP and combined Purch/Serv/Labor/Consult into one number.
- 19005RKC: Current Status: Added FY06 Obligations used Travel / for EDP and combined Purch/Serv/Labor/Consult into one number.

| ID | WBS | Activity | Type | Duration | Start | Finish | Predecessors | Complete | Planned start | Planned finish | Constraint | Resources | Cost | Actual cost | Planned FinishUDF | Calculated Remaining Total Cost | MONTHLY EV COST | RESP - Responsibility | STRT%COMP for CM EVM | FNSH%COMP for CM EVM | EVMS Reporting Codes | CAM RESPONSIBLE | CR 09-012 | Milestone Level | Remaining Material Cost Based on % Compl | Claimed Material Cost Based on % Complet | Initial Claimed Material Calc | Claimed Material Divider | ReBaseline Actuals Adjustment | Risk Item Number | CR 07-009 | CR 08-025 |
| --- | --- | --- | --- | --- | --- | --- | --- | --- | --- | --- | --- | --- | --- | --- | --- | --- | --- | --- | --- | --- | --- | --- | --- | --- | --- | --- | --- | --- | --- | --- | --- | --- |
|  | 1 | **1.1.1.1.1.1 R1 Testing in FEL** |  |  |  |  |  |  |  |  |  |  |  |  |  |  |  |  |  |  |  |  |  |  |  |  |  |  |  |  |  |  |
|  | 2 | **1.1.1.1.1.2 RF Window** |  |  |  |  |  |  |  |  |  |  |  |  |  |  |  |  |  |  |  |  |  |  |  |  |  |  |  |  |  |  |
|  | 3 | **1.1.1.1.1.3 Cavity Processing** |  |  |  |  |  |  |  |  |  |  |  |  |  |  |  |  |  |  |  |  |  |  |  |  |  |  |  |  |  |  |
|  | 4 | **1.1.1.1.1.4 Tuner** |  |  |  |  |  |  |  |  |  |  |  |  |  |  |  |  |  |  |  |  |  |  |  |  |  |  |  |  |  |  |
|  | 2 | **1.1.1.1.2 Post R1 Plan** |  |  | 2006-10-02 | 2013-08-30 |  |  |  |  |  |  |  |  |  |  |  |  |  |  |  |  |  |  |  |  |  |  |  |  |  |  |
|  | 1 | **1.1.1.1.2.1 Cavity** |  |  | 2006-10-02 | 2013-08-30 |  |  |  |  |  |  |  |  |  |  |  |  |  |  |  |  |  |  |  |  |  |  |  |  |  |  |
| 111121000 |  | Fab. C100 Niobium Cavities x 2 (CAVITY) |  | 21d | 2006-10-02 A | 2006-10-31 A | 9-070M | 100% | 2006-10-02 | 2006-10-30 |  | MECH ENG [17.6 h]; MECH ENG [22 h]; MECH ENG [8.8 h]; ELEC TECH [22 h]; MECH ENG [7.04 h]; MECH TECH [30.8 h]; MECH DES [13.2 h]; MSHOP | 8,840.46 | 6,145.6 | 2006-10-16 | 0 | 8840.4544 | HOGAN J | 1 | 1 | N/A | JOHN H | 09-012 |  |  |  |  |  |  |  |  |  |
| 111121005M |  | Cavity Fabrication Complete (Finish 9/29/06) (CAVITY) | milestone | 0d | 2006-11-01 A | 2006-11-01 A | 111121000 | 100% | 2006-10-16 | 2006-10-16 |  |  |  |  | 2006-10-16 |  | 0 | HOGAN J | 1 | 1 | N/A | JOHN H |  | 9 |  |  |  |  |  |  |  |  |
| 111121010 |  | Re-Baseline Actuals Adjustment |  | 1d | 2013-08-30 A | 2013-08-30 A |  | 100% | 2013-09-03 | 2013-09-03 |  | PROCUREMENT>$50K 69 NO ESCALATION | 69,321.11 |  |  |  | 69321.11 |  |  |  |  |  |  |  | 0 | 69321.11 | 6932111 | 100 | ADJ |  |  |  |
|  | 2 | **1.1.1.1.2.2 Power Coupler** |  |  | 2006-10-02 | 2006-12-15 |  |  |  |  |  |  |  |  |  |  |  |  |  |  |  |  |  |  |  |  |  |  |  |  |  |  |
| 111122000 |  | Fabricate FPC for HTB Testing (PWR CPLR) |  | 52d | 2006-10-02 A | 2006-12-15 A | 9-070M | 100% | 2006-10-02 | 2006-12-14 |  | PROCUREMENT>$50K 69; MECH ENG [40 h]; MECH DES [80 h]; MECH ENG [80 h]; ELEC TECH [80 h]; PROCUREMENT<$50K 60 | 84,851.6 | 16,741.6 | 2007-01-02 | 0 | 84851.6 | HOGAN J | 1 | 1 | N/A | JOHN H |  |  | 0 | 68110 | 6811000 | 100 |  |  |  |  |
| 111122005M |  | Power Coupler Prototype Fab Complete (PWR CPLR) | milestone | 0d | 2006-12-15 A | 2006-12-15 A | 111122000 | 100% | 2007-01-02 | 2007-01-02 |  |  |  |  | 2007-01-02 |  | 0 | HOGAN J | 1 | 1 | N/A | JOHN H |  | 9 |  |  |  |  |  |  |  |  |
|  | 3 | **1.1.1.1.2.3 Evaluation** |  |  | 2006-11-21 | 2007-02-28 |  |  |  |  |  |  |  |  |  |  |  |  |  |  |  |  |  |  |  |  |  |  |  |  |  |  |
| 111123000 |  | Conduct VTA Test C100 Cavities (EVALUATION) |  | 4d | 2006-11-21 A | 2006-11-29 A | 111121000, 111121005M | 100% | 2006-11-21 | 2006-11-28 |  | MECH ENG [80 h]; PROCUREMENT<$50K 60; ELEC ENG [80 h]; SCIENTIST [16 h]; MECH TECH [40 h]; MECH ENG [160 h]; ELEC TECH [80 h]; MECH TECH [160 h]; MECH TECH [32 h] | 47,262.4 | 40,042.4 | 2006-12-22 | 0 | 47262.4 | HOGAN J | 1 | 1 | N/A | JOHN H |  |  | 0 | 7220 | 722000 | 100 |  |  |  |  |
| 111123005 |  | Conduct Integrated Test in HTB (EVALUATION) |  | 23d | 2006-12-22 A | 2007-02-02 A | 111123000, 111122005M FS+20d, 111124000 | 100% | 2006-12-22 | 2007-02-01 |  | MECH ENG [40 h]; MECH TECH [40 h]; MECH ENG [120 h]; PROCUREMENT<$50K 60; ELEC ENG [400 h]; MECH DES [40 h] | 48,895.6 | 43,735.6 | 2007-03-15 | 0 | 48895.6 | HOGAN J | 1 | 1 | N/A | JOHN H |  |  | 0 | 5160 | 516000 | 100 |  |  |  |  |
| 111123010M |  | Integrated Testing Complete (EVALUATION) | milestone | 0d | 2007-02-02 A | 2007-02-02 A | 111123005 | 100% | 2007-03-15 | 2007-03-15 |  |  |  |  | 2007-03-15 |  | 0 | HOGAN J | 1 | 1 | N/A | JOHN H |  | 9 |  |  |  |  |  |  |  |  |
| 111123015 |  | 1/4 Cryomodule CR Accounting Change Request (Finish by 4/30/07) |  | 16d | 2007-02-05 A | 2007-02-28 A | 111123010M | 100% | 2007-02-05 | 2007-02-27 | finish on or before 2007-04-30 | SUPPLIES & MATERIALS; ELEC TECH [32.4 h]; ELEC ENG [-162.51 h]; MECH ENG [891.1 h]; MECH TECH [1152.53 h]; PROCUREMENT>$50K 69; SCIENTIST [-8.8 h]; SR STAFF [178 h]; PROCUREMENT<$50K 60; MECH DES [175.2 h]; MSHOP | 194,643.66 | 116,803.73 | 2007-01-24 | 0 | 195226.583447 | HOGAN J | 1 | 1 | N/A | JOHN H | 09-012 |  | 0 | 76905 | 7690500 | 100 |  | 2,3,4 | 07-009 |  |
|  | 4 | **1.1.1.1.2.4 Tuner** |  |  | 2006-11-01 | 2006-11-20 |  |  |  |  |  |  |  |  |  |  |  |  |  |  |  |  |  |  |  |  |  |  |  |  |  |  |
| 111124000 |  | Procure Prototype Components (TUNER) |  | 13d | 2006-11-01 A | 2006-11-20 A | 111121000 | 100% | 2006-11-01 | 2006-11-17 |  | PROCUREMENT<$50K 60; MECH ENG [16 h]; MECH DES [32 h]; MECH ENG [8 h]; PROCUREMENT>$50K 69 | 55,488.96 | 3,888.96 | 2006-12-15 | 0 | 55488.96 | HOGAN J | 1 | 1 | N/A | JOHN H |  |  | 0 | 51600 | 5160000 | 100 |  |  |  |  |
|  | 3 | **1.1.1.1.3 Critical Decisions** |  |  |  |  |  |  |  |  |  |  |  |  |  |  |  |  |  |  |  |  |  |  |  |  |  |  |  |  |  |  |
|  | 1 | **1.1.1.1.3.1 CD2A** |  |  |  |  |  |  |  |  |  |  |  |  |  |  |  |  |  |  |  |  |  |  |  |  |  |  |  |  |  |  |
|  | 2 | **1.1.1.1.3.2 CD2B** |  |  |  |  |  |  |  |  |  |  |  |  |  |  |  |  |  |  |  |  |  |  |  |  |  |  |  |  |  |  |
|  | 3 | **1.1.1.1.3.3 CD3A** |  |  |  |  |  |  |  |  |  |  |  |  |  |  |  |  |  |  |  |  |  |  |  |  |  |  |  |  |  |  |
|  | 4 | **1.1.1.1.3.4 CD3B** |  |  |  |  |  |  |  |  |  |  |  |  |  |  |  |  |  |  |  |  |  |  |  |  |  |  |  |  |  |  |
|  | 5 | **1.1.1.1.3.5 CD4** |  |  |  |  |  |  |  |  |  |  |  |  |  |  |  |  |  |  |  |  |  |  |  |  |  |  |  |  |  |  |
|  | 4 | **1.1.1.1.4 HOM MEASUREMENTS** |  |  | 2008-03-13 | 2008-09-30 |  |  |  |  |  |  |  |  |  |  |  |  |  |  |  |  |  |  |  |  |  |  |  |  |  |  |
| 11114000 |  | Prepare for HTB test |  | 48d | 2008-03-13 A | 2008-05-19 A | 9-080M FS+107d | 100% |  |  |  | MECH DES [60 h]; MECH ENG [240 h]; SUPPLIES & MATERIALS | 24,390.4 | 17,390.4 |  | 0 | 24390.4 | HOGAN J | 1 | 1 | N/A | JOHN H |  |  |  |  |  |  |  |  |  | 08-025 |
| 11114005 |  | Procure/fabricate/modify HOM hardware |  | 62d | 2008-03-13 A | 2008-06-10 A | 11114000 FS-9d | 100% | 2008-03-13 | 2008-06-09 |  | MECH TECH [180 h] | 7,056 | 7,056 |  | 0 | 7056 | HOGAN J | 1 | 1 | N/A | JOHN H |  |  |  |  |  |  |  |  |  | 08-025 |
| 11114010 |  | Assemble HTB |  | 26d | 2008-04-16 A | 2008-05-21 A | 9-080M | 100% |  |  |  | MECH TECH [60 h]; MECH ENG [72 h] | 6,804.48 | 6,804.48 |  | 0 | 6804.48 | HOGAN J | 1 | 1 | N/A | JOHN H | 09-012 |  |  |  |  |  |  |  |  | 08-025 |
| 11114015M |  | HTB Assembly Completed | milestone | 0d | 2008-05-21 A | 2008-05-21 A | 11114010 | 100% | 2008-06-24 | 2008-06-24 |  |  |  |  |  |  | 0 | HOGAN J | 1 | 1 | M | JOHN H |  |  |  |  |  |  |  |  |  | 08-025 |
| 11114020 |  | Install into CMTF/Cooldown |  | 2d | 2008-05-22 A | 2008-05-23 A | 11114015M | 100% |  |  |  | MECH ENG [80 h] | 4,947.2 | 4,947.2 |  | 0 | 4947.2 | HOGAN J | 1 | 1 | N/A | JOHN H | 09-012 |  |  |  |  |  |  |  |  | 08-025 |
| 11114025 |  | Perform HOM measurements in HTB |  | 13d | 2008-05-29 A | 2008-06-17 A | 11114020 | 100% | 2008-05-29 | 2008-06-16 |  | SR STAFF [80 h] | 7,972.8 | 7,972.8 |  | 0 | 7972.8 | HOGAN J | 1 | 1 | N/A | JOHN H |  |  |  |  |  |  |  |  |  | 08-025 |
| 11114035 |  | Perform thermal measurements |  | 18d | 2008-06-02 A | 2008-06-26 A | 11114030M | 100% | 2008-06-02 | 2008-06-25 |  | SCIENTIST [80 h] | 4,981.6 | 4,981.6 |  | 0 | 4981.6 | HOGAN J | 1 | 1 | N/A | JOHN H |  |  |  |  |  |  |  |  |  | 08-025 |
| 11114045 |  | Data Analysis |  | 35d | 2008-06-02 A | 2008-07-21 A | 11114035 | 100% |  |  |  | SR STAFF [156 h] | 15,546.96 | 15,546.96 |  | 0 | 15546.96 | HOGAN J | 1 | 1 | N/A | JOHN H |  |  |  |  |  |  |  |  |  | 08-025 |
| 11114030M |  | Q's measured and analyzed Completed | milestone | 0d | 2008-06-17 A | 2008-06-17 A | 11114025 | 100% | 2008-07-08 | 2008-07-08 |  |  |  |  |  |  | 0 | HOGAN J | 1 | 1 | M | JOHN H |  |  |  |  |  |  |  |  |  | 08-025 |
| 11114040 |  | WarmUp & Disassemble |  | 2d | 2008-06-26 A | 2008-06-30 A | 11114035 | 100% | 2008-06-26 | 2008-06-27 |  | MECH ENG [120 h]; MECH TECH [120 h] | 12,124.8 | 12,124.8 |  | 0 | 12124.8 | HOGAN J | 1 | 1 | N/A | JOHN H |  |  |  |  |  |  |  |  |  | 08-025 |
| 11114055 |  | VTA tests: prep and execution |  | 14.5d | 2008-06-30 A | 2008-07-21 A | 11114005, 11114040, 11114050M | 100% |  |  |  | MECH TECH [160 h]; ELEC ENG [80 h]; MECH ENG [80 h] | 16,198.36 | 16,198.4 |  | 0 | 16198.4 | HOGAN J | 1 | 1 | N/A | JOHN H |  |  |  |  |  |  |  |  |  | 08-025 |
| 11114050M |  | Interim report Completed | milestone | 0d | 2008-07-11 A | 2008-07-11 A | 11114035 FS+11d | 100% | 2008-08-01 | 2008-08-01 |  |  |  |  |  |  | 0 | HOGAN J | 1 | 1 | M | JOHN H |  |  |  |  |  |  |  |  |  | 08-025 |
| 11114060 |  | Disassemble and store components |  | 4.5d | 2008-07-21 A | 2008-07-28 A | 11114055 | 100% |  |  |  | MECH TECH [80 h] | 3,136 | 3,136 |  | 0 | 3136 | HOGAN J | 1 | 1 | N/A | JOHN H |  |  |  |  |  |  |  |  |  | 08-025 |
| 11114065 |  | Data Analysis |  | 4.5d | 2008-07-21 A | 2008-07-28 A | 11114045, 11114055 | 100% |  |  |  | SR STAFF [80 h] | 7,972.8 | 7,972.8 |  | 0 | 7972.8 | HOGAN J | 1 | 1 | N/A | JOHN H |  |  |  |  |  |  |  |  |  | 08-025 |
| 11114070M |  | Final Report and All Tasks Completed | milestone | 0d | 2008-09-30 A | 2008-09-30 A | 11114065, 11114060 | 100% | 2008-10-01 | 2008-10-01 |  |  |  |  |  |  | 0 | HOGAN J | 1 | 1 | M | JOHN H |  |  |  |  |  |  |  |  |  | 08-025 |

| ID | WBS | Activity | Type | Duration | Start | Finish | Predecessors | Complete | Planned start | Planned finish | Constraint | Resources | Cost | Actual cost | Calculated Remaining Total Cost | MONTHLY EV COST | RESP - Responsibility | STRT%COMP for CM EVM | FNSH%COMP for CM EVM | CR 08-025 | EVMS Reporting Codes | CAM RESPONSIBLE | CR 08-054 | CR 10-027 | CR 10-064 | CR 11-051 | CR 12-018 | Remaining Material Cost Based on % Compl | Claimed Material Cost Based on % Complet | Initial Claimed Material Calc | Claimed Material Divider | Planned FinishUDF | Milestone Level | ReBaseline Actuals Adjustment | CR 08-004 | CR 07-019 |
| --- | --- | --- | --- | --- | --- | --- | --- | --- | --- | --- | --- | --- | --- | --- | --- | --- | --- | --- | --- | --- | --- | --- | --- | --- | --- | --- | --- | --- | --- | --- | --- | --- | --- | --- | --- | --- |
|  | 5 | **1.1.1.1.5 WAVEGUIDE FUNDAMENTAL POWER COUPLER TESTS** |  |  | 2008-06-24 | 2009-11-30 |  |  |  |  |  |  |  |  |  |  |  |  |  |  |  |  |  |  |  |  |  |  |  |  |  |  |  |  |  |  |
| 11115000 |  | Developement of Documentation & Detail Plans |  | 48d | 2008-06-24 A | 2008-08-29 A | 9-080M | 100% |  |  |  | SUPPLIES & MATERIALS; SCIENTIST [40 h]; COMP SCIENT [40 h]; MECH ENG [80 h]; MECH TECH [200 h] | 18,592.8 | 17,592.8 | 0 | 18592.8 | HOGAN J | 1 | 1 | 08-025 | H | JOHN H | 08-054 | 10-027 | 10-064 | 11-051 | 12-018F |  |  |  |  |  |  |  |  |  |
| 11115005 |  | Vendor Fab 15 Waveguide Fundamental Power Couplers |  | 354d | 2008-06-30 A | 2009-11-30 A | 11115000 | 100% |  |  |  | PROCUREMENT<$50K 60 NO ESCALATION FY09; PROCUREMENT>$50K 69 NO ESCALATION FY09 | 79,305 |  | 0 | 79305 | HOGAN J | 1 | 1 | 08-025 | D | JOHN H | 08-054 | 10-027 | 10-064 | 11-051 | 12-018F | 0 | 79305 | 7930500 | 100 |  |  |  |  |  |
|  | 2 | **1.1.1.2 POWER SYSTEMS** |  |  | 2007-07-02 | 2013-08-30 |  |  |  |  |  |  |  |  |  |  |  |  |  |  |  |  |  |  |  |  |  |  |  |  |  |  |  |  |  |  |
| 1112000 |  | Conduct Interlock Check Out (POWER SYSTEMS) |  | 5d | 2007-07-02 A | 2007-07-09 A | 9-070M FS+108d | 100% |  |  |  | ELEC ENG [40 h]; ELEC TECH [40 h] | 3,921.69 | 3,921.69 | 0 | 4299.6 | HOVATER C | 1 | 1 |  | N/A | BILL M |  |  |  |  |  |  |  |  |  | 2007-03-28 |  |  |  |  |
| 1112005 |  | Conduct RF - Cavity System Tests (POWER SYSTEMS) |  | 5d | 2007-07-10 A | 2007-07-17 A | 1112000 FS+12d | 100% | 2007-07-10 | 2007-07-16 | start on or after 2007-07-10 | ELEC TECH [80 h]; COMP SCIENT [80 h]; SCIENTIST [80 h]; ELEC ENG [320 h] | 31,632.94 | 31,632.94 | 0 | 32750.4 | HOVATER C | 1 | 1 |  | N/A | BILL M |  |  |  |  |  |  |  |  |  | 2007-06-15 |  |  |  |  |
| 1112010 |  | Report Writing (POWER SYSTEMS) |  | 9d | 2007-07-18 A | 2007-07-31 A | 1112005 FS-13d | 100% | 2007-07-18 | 2007-07-30 |  | ELEC ENG [40 h] | 2,412.63 | 2,412.63 | 0 | 2484.8 | HOVATER C | 1 | 1 |  | N/A | BILL M |  |  |  |  |  |  |  |  |  | 2007-06-15 |  |  |  |  |
| 1112015M |  | Report sent to DOE (POWER SYSTEMS) | milestone | 0d | 2007-07-31 A | 2007-07-31 A | 1112010 FS+10d | 100% | 2007-06-29 | 2007-06-29 |  |  |  |  |  | 0 | HOVATER C | 1 | 1 |  | N/A | BILL M |  |  |  |  |  |  |  |  |  | 2007-06-29 | 9 |  |  |  |
| 1112020 |  | Re-Baseline Actuals Adjustment |  | 1d | 2013-08-30 A | 2013-08-30 A |  | 100% | 2013-09-03 | 2013-09-03 |  | PROCUREMENT>$50K 69 NO ESCALATION | -11,919.46 |  |  |  |  |  |  |  |  |  |  |  |  |  |  |  |  |  | 100 |  |  | ADJ |  |  |
|  | 3 | **1.1.1.3 CRYOGENICS** |  |  |  |  |  |  |  |  |  |  |  |  |  |  |  |  |  |  |  |  |  |  |  |  |  |  |  |  |  |  |  |  |  |  |
|  | 4 | **1.1.1.4 BEAM TRANSPORT** |  |  | 2007-11-13 | 2013-08-30 |  |  |  |  |  |  |  |  |  |  |  |  |  |  |  |  |  |  |  |  |  |  |  |  |  |  |  |  |  |  |
| 1114000 |  | Fabricate QP and QR Laminations |  | 136d | 2007-11-13 A | 2008-06-05 A | 9-080M FS+23d | 100% |  |  |  | PROCUREMENT<$50K 60 | 28,480.44 |  | 0 | 28480.44 | BEVINS M | 1 | 1 |  | N/A | MIKE B |  |  |  |  |  | 0 | 28480.44 | 2848044 | 100 |  |  |  | 08-004 |  |
| 1114005 |  | Fabricate Coils and Assemble magnets |  | 147d | 2007-12-03 A | 2008-07-09 A | 1114000 FS-42d | 100% |  |  |  | MECH ENG [60 h]; MECH TECH [480 h]; PROCUREMENT<$50K 60 | 28,201.85 | 22,526.4 | 0 | 28201.85 | BEVINS M | 1 | 1 |  | N/A | MIKE B |  |  |  |  |  | 0 | 5675.45 | 567545 | 100 |  |  |  | 08-004 |  |
| 1114010 |  | Test and measure QP and QR |  | 44d | 2008-06-30 A | 2008-08-29 A | 1114005 FS-14d | 100% |  |  |  | MECH TECH [172 h]; PROCUREMENT<$50K 60; MECH ENG [80 h] | 16,333.15 | 11,689.6 | 0 | 16333.15 | BEVINS M | 1 | 1 |  | N/A | MIKE B |  |  |  |  |  | 0 | 4643.55 | 464355 | 100 |  |  |  | 08-004 |  |
| 1114015 |  | Re-Baseline Actuals Adjustment |  | 1d | 2013-08-30 A | 2013-08-30 A |  | 100% | 2013-09-03 | 2013-09-03 |  | PROCUREMENT>$50K 69 NO ESCALATION | 45,652.72 |  |  | 45652.72 |  |  |  |  |  |  |  |  |  |  |  | 0 | 45652.72 | 4565272 | 100 |  |  | ADJ |  |  |
|  | 5 | **1.1.1.5 EXTRACTION** |  |  |  |  |  |  |  |  |  |  |  |  |  |  |  |  |  |  |  |  |  |  |  |  |  |  |  |  |  |  |  |  |  |  |
|  | 6 | **1.1.1.6 INSTRUMENTATION, CONTROLS, & SAFETY SYSTEMS** |  |  |  |  |  |  |  |  |  |  |  |  |  |  |  |  |  |  |  |  |  |  |  |  |  |  |  |  |  |  |  |  |  |  |
|  | 2 | **1.1.2 HALL A** |  |  | 2013-08-30 | 2013-08-30 |  |  |  |  |  |  |  |  |  |  |  |  |  |  |  |  |  |  |  |  |  |  |  |  |  |  |  |  |  |  |
|  | 1 | **1.1.2.1 MAGNET** |  |  | 2013-08-30 | 2013-08-30 |  |  |  |  |  |  |  |  |  |  |  |  |  |  |  |  |  |  |  |  |  |  |  |  |  |  |  |  |  |  |
| 1121000 |  | Re-Baseline Actuals Adjustment |  | 1d | 2013-08-30 A | 2013-08-30 A |  | 100% | 2013-09-03 | 2013-09-03 |  | PROCUREMENT>$50K 69 NO ESCALATION |  |  |  | 0 |  |  |  |  |  |  |  |  |  |  |  |  |  |  |  |  |  | ADJ |  |  |
|  | 2 | **1.1.2.2 DETECTOR** |  |  |  |  |  |  |  |  |  |  |  |  |  |  |  |  |  |  |  |  |  |  |  |  |  |  |  |  |  |  |  |  |  |  |
|  | 3 | **1.1.2.3 COMPUTING** |  |  |  |  |  |  |  |  |  |  |  |  |  |  |  |  |  |  |  |  |  |  |  |  |  |  |  |  |  |  |  |  |  |  |
|  | 4 | **1.1.2.4 ELECTRONICS** |  |  |  |  |  |  |  |  |  |  |  |  |  |  |  |  |  |  |  |  |  |  |  |  |  |  |  |  |  |  |  |  |  |  |
|  | 5 | **1.1.2.5 BEAMLINE** |  |  |  |  |  |  |  |  |  |  |  |  |  |  |  |  |  |  |  |  |  |  |  |  |  |  |  |  |  |  |  |  |  |  |
|  | 6 | **1.1.2.6 INFRASTRUCTURE** |  |  |  |  |  |  |  |  |  |  |  |  |  |  |  |  |  |  |  |  |  |  |  |  |  |  |  |  |  |  |  |  |  |  |
|  | 3 | **1.1.3 HALL B** |  |  | 2006-10-02 | 2013-08-30 |  |  |  |  |  |  |  |  |  |  |  |  |  |  |  |  |  |  |  |  |  |  |  |  |  |  |  |  |  |  |
|  | 1 | **1.1.3.1 TORUS MAGNET R&D** |  |  | 2007-07-02 | 2013-08-30 |  |  |  |  |  |  |  |  |  |  |  |  |  |  |  |  |  |  |  |  |  |  |  |  |  |  |  |  |  |  |
| 1131005 |  | Conduct SC Magnet Cable Testing |  | 33d | 2007-07-02 A | 2007-08-16 A | 9-070M FS+174d | 100% |  |  |  | PROCUREMENT<$50K 60 | 43,000 |  | 0 | 43000 | ELOUADRHIRI L | 1 | 1 |  | N/A | LATIFA E |  |  |  |  |  | 0 | 43000 | 4300000 | 100 |  |  |  |  | 07-019 |
| 1131010 |  | Re-Baseline Actuals Adjustment |  | 1d | 2013-08-30 A | 2013-08-30 A |  | 100% | 2013-09-03 | 2013-09-03 |  | PROCUREMENT>$50K 69 NO ESCALATION | -3,000 |  |  |  |  |  |  |  |  |  |  |  |  |  |  |  |  |  | 100 |  |  | ADJ |  |  |

| ID | WBS | Activity | Type | Duration | Start | Finish | Predecessors | Complete | Planned start | Planned finish | Resources | Cost | Actual cost | Planned FinishUDF | Calculated Remaining Total Cost | MONTHLY EV COST | RESP - Responsibility | Special | STRT%COMP for CM EVM | FNSH%COMP for CM EVM | EVMS Reporting Codes | CAM RESPONSIBLE | Remaining Material Cost Based on % Compl | Claimed Material Cost Based on % Complet | Initial Claimed Material Calc | Claimed Material Divider | Milestone Level | CR 09-012 | CR 07-027 | HALL DUR EST | WBS ASSIGNMENT | CR 08-021 | CR 08-022 | ReBaseline Actuals Adjustment |
| --- | --- | --- | --- | --- | --- | --- | --- | --- | --- | --- | --- | --- | --- | --- | --- | --- | --- | --- | --- | --- | --- | --- | --- | --- | --- | --- | --- | --- | --- | --- | --- | --- | --- | --- |
|  | 2 | **1.1.3.2 DETECTOR R&D** |  |  | 2006-10-02 | 2013-08-30 |  |  |  |  |  |  |  |  |  |  |  |  |  |  |  |  |  |  |  |  |  |  |  |  |  |  |  |  |
| 1132021RKC |  | FY06 Obligations RKC |  | 270d | 2006-10-02 A | 2007-10-31 A | 9-070M | 100% |  |  | SUPPLIES & MATERIALS | 24,045.6 |  | 2007-03-30 | 0 | 24045.6 | PARKINSON J | LR | 1 | 1 | N/A | LATIFA E |  |  |  |  |  |  |  |  |  |  |  |  |
| 1132028 |  | FY07-HTCC - Testing of the prototype (DTCTR R&D) |  | 244d | 2006-10-02 A | 2007-09-25 A | 1132026M | 100% |  |  | PD UNIV STUDNT [217.6 h]; CONTRB UNIV LBR [121 h]; SCIENTIST [34.4 h] | 4,279.54 | 4,279.54 | 2007-01-04 | 0 | 4373.256 | ELOUADRHIRI L |  | 1 | 1 | N/A | LATIFA E |  |  |  |  |  |  |  |  |  |  |  |  |
| 1132055 |  | FY07-DC - Mechanical protoptyping (DTCTR R&D) |  | 255d | 2006-10-02 A | 2007-10-10 A | 1132054M | 100% |  |  | MECH TECH [479.62 h]; MECH DES [218.01 h]; MECH ENG [22 h]; PROCUREMENT<$50K 60; CONTRB UNIV LBR [479.62 h] | 57,912.17 | 29,694.58 | 2007-04-06 | 0 | 58312.500747 | ELOUADRHIRI L |  | 1 | 1 | N/A | LATIFA E | 0 | 28209 | 2820900 | 100 |  |  |  |  |  |  |  |  |
| 1132060 |  | FY07-DC - Electrical prototyping (DTCTR R&D) |  | 258d | 2006-10-02 A | 2007-10-16 A | 9-070M | 100% | 2006-10-02 | 2007-10-15 | ELEC DES [239.81 h]; ELEC ENG [21.8 h]; PROCUREMENT<$50K 60; ELEC TECH [109.01 h] | 33,384.07 | 16,407.96 | 2007-04-06 | 0 | 33653.145673 | ELOUADRHIRI L |  | 1 | 1 | N/A | LATIFA E | 0 | 16924 | 1692400 | 100 |  |  |  |  |  |  |  |  |
| 1132095 |  | FY07-SVT - prototyping (DTCTR R&D) |  | 259d | 2006-10-02 A | 2007-10-16 A | 1132094M | 100% |  |  | CONTRB UNIV LBR [479.62 h]; PROCUREMENT<$50K 60; ELEC ENG [545.03 h]; SCIENTIST [43.6 h] | 62,806.02 | 37,365.36 | 2007-04-06 | 0 | 64111.465131 | ELOUADRHIRI L |  | 1 | 1 | N/A | LATIFA E | 0 | 25389 | 2538900 | 100 |  |  |  |  |  |  |  |  |
| 1132026M |  | FY07-HTCC -R&D Plans & Initial Safety Assessment (DTCTR R&D) | milestone | 0d | 2006-11-01 A | 2006-11-01 A | 9-070M | 100% | 2006-10-02 | 2006-10-02 |  |  |  | 2006-10-02 |  | 0 | ELOUADRHIRI L |  | 1 | 1 | N/A | LATIFA E |  |  |  |  | 9 |  |  |  |  |  |  |  |
| 1132033M |  | FY07-EC -R&D Plans & Initial Safety Assessment (DTCTR R&D) | milestone | 0d | 2006-11-01 A | 2006-11-01 A | 9-070M | 100% | 2006-10-02 | 2006-10-02 |  |  |  | 2006-10-02 |  | 0 | ELOUADRHIRI L |  | 1 | 1 | N/A | LATIFA E |  |  |  |  | 9 |  |  |  |  |  |  |  |
| 1132035 |  | FY07-EC - Fullscale prototype design (DTCTR R&D) |  | 99d | 2006-11-01 A | 2007-04-02 A | 1132033M | 100% |  |  | SCIENTIST [22 h]; CONTRB UNIV LBR [109.01 h]; PD UNIV STUDNT [200 h] | 3,401.66 | 3,401.66 | 2007-01-31 | 0 | 3402.18 | ELOUADRHIRI L |  | 1 | 1 | N/A | LATIFA E |  |  |  |  |  |  |  |  |  |  |  |  |
| 1132054M |  | FY07-DC Plans & Initial Safety Assessment (DTCTR R&D) | milestone | 0d | 2006-11-01 A | 2006-11-01 A | 9-070M | 100% | 2006-10-02 | 2006-10-02 |  |  |  | 2006-10-02 |  | 0 | ELOUADRHIRI L |  | 1 | 1 | N/A | LATIFA E |  |  |  |  | 9 |  |  |  |  |  |  |  |
| 1132069M |  | FY07-FTOF -R&D Plans & Initial Safety Assessment (DTCTR R&D) | milestone | 0d | 2006-11-01 A | 2006-11-01 A | 9-070M | 100% | 2006-10-02 | 2006-10-02 |  |  |  | 2006-10-02 |  | 0 | ELOUADRHIRI L |  | 1 | 1 | N/A | LATIFA E |  |  |  |  | 9 |  |  |  |  |  |  |  |
| 1132070 |  | FY07-FTOF - Building the prototype (DTCTR R&D) |  | 222d | 2006-11-01 A | 2007-09-25 A | 1132069M | 100% |  |  | PROCUREMENT<$50K 60 | 16,926 |  | 2007-02-28 | 0 | 16926 | ELOUADRHIRI L |  | 1 | 1 | N/A | LATIFA E | 0 | 16926 | 1692600 | 100 |  | 09-012 |  |  |  |  |  |  |
| 1132075 |  | FY07-FTOF - Testing and data analysis from the prototype (DTCTR R&D) |  | 225d | 2006-11-01 A | 2007-09-28 A | 1132070 FS-25d | 100% |  |  | PROCUREMENT<$50K 60 | 11,284 |  | 2007-09-28 | 0 | 11284 | ELOUADRHIRI L |  | 1 | 1 | N/A | LATIFA E | 0 | 11284 | 1128400 | 100 |  | 09-012 |  |  |  |  |  |  |
| 1132079M |  | FY07-CTOF -R&D Plans & Initial Safety Assessment (DTCTR R&D) | milestone | 0d | 2006-11-01 A | 2006-11-01 A | 9-070M | 100% | 2006-10-02 | 2006-10-02 |  |  |  | 2006-10-02 |  | 0 | ELOUADRHIRI L |  | 1 | 1 | N/A | LATIFA E |  |  |  |  | 9 |  |  |  |  |  |  |  |
| 1132080 |  | FY07-CTOF - Design of the prototype (DTCTR R&D) |  | 98d | 2006-11-01 A | 2007-03-30 A | 1132079M | 100% |  |  |  |  |  | 2006-12-19 |  | 0 | ELOUADRHIRI L |  | 1 | 1 | N/A | LATIFA E |  |  |  |  |  | 09-012 |  |  |  |  |  |  |
| 1132085 |  | FY07-CTOF - Building the prototype (DTCTR R&D) |  | 108d | 2006-11-01 A | 2007-04-13 A | 1132080 FS-50d | 100% |  |  |  |  |  | 2007-04-03 |  | 0 | ELOUADRHIRI L |  | 1 | 1 | N/A | LATIFA E |  |  |  |  |  | 09-012 |  |  |  |  |  |  |
| 1132094M |  | FY07-SVT -R&D Plans & Initial Safety Assessment (DTCTR R&D) | milestone | 0d | 2006-11-01 A | 2006-11-01 A | 9-070M | 100% | 2006-10-02 | 2006-10-02 |  |  |  | 2006-10-02 |  | 0 | ELOUADRHIRI L |  | 1 | 1 | N/A | LATIFA E |  |  |  |  | 9 |  |  |  |  |  |  |  |
| 1132030 |  | FY07-HTCC - Analysis of the prototype (DTCTR R&D) |  | 124d | 2007-04-02 A | 2007-09-25 A | 1132028 FS-21d | 100% |  |  | CONTRB UNIV LBR [108.8 h]; PD UNIV STUDNT [192.4 h]; SCIENTIST [22 h] | 3,181.98 | 3,181.98 | 2007-09-28 | 0 | 3226.228504 | ELOUADRHIRI L |  | 1 | 1 | N/A | LATIFA E |  |  |  |  |  |  |  |  |  |  |  |  |
| 1132045 |  | FY07-EC - Manufacturing the box and fixtures for the full scale protoptye (DTCTR R&D) |  | 15d | 2007-04-02 A | 2007-04-20 A | 1132035 | 100% |  |  | PROCUREMENT<$50K 60; MECH DES [43.6 h]; MECH TECH [387.6 h]; MECH ENG [22 h] | 47,020.48 | 18,810.48 | 2007-05-03 | 0 | 46957.309261 | ELOUADRHIRI L |  | 1 | 1 | N/A | LATIFA E | 0 | 28210 | 2821000 | 100 |  |  |  |  |  |  |  |  |
| 1132090 |  | FY07-CTOF - Testing of the prototype (DTCTR R&D) |  | 117d | 2007-04-02 A | 2007-09-15 A | 1132085 FS-21d, 1132080 FS-21d | 100% | 2007-04-02 | 2007-09-14 | TRAVEL | 15,890 |  | 2007-09-28 | 0 | 15890 | ELOUADRHIRI L |  | 1 | 1 | N/A | LATIFA E |  |  |  |  |  | 09-012 |  |  |  |  |  |  |
| 1132050 |  | FY07-EC - Assembly & testing of the protoptype (DTCTR R&D) |  | 88d | 2007-04-23 A | 2007-08-24 A | 1132045 | 100% |  |  | MECH TECH [222.8 h]; VISTNG USERS [523.2 h] | 17,568.07 | 17,568.07 | 2007-09-28 | 0 | 17428.085115 | ELOUADRHIRI L |  | 1 | 1 | N/A | LATIFA E |  |  |  |  |  |  |  |  |  |  |  |  |
| 1132030M |  | FY07-HTCC -R&D Report (DTCTR R&D) | milestone | 0d | 2007-05-31 A | 2007-05-31 A | 1132030 | 100% | 2007-09-28 | 2007-09-28 |  |  |  | 2007-09-28 |  | 0 | ELOUADRHIRI L |  | 1 | 1 | N/A | LATIFA E |  |  |  |  | 4 |  |  |  |  |  |  |  |
| 1132065 |  | FY07-DC - Testing & analysis of the prototype (DTCTR R&D) |  | 90d | 2007-06-15 A | 2007-10-22 A | 1132055 FS-26d, 1132060 FS-26d | 100% |  |  | ELEC TECH [108.8 h]; ELEC ENG [21.6 h]; ELEC DES [239.6 h] | 15,919.65 | 15,919.65 | 2007-09-28 | 0 | 16060.604322 | ELOUADRHIRI L |  | 1 | 1 | N/A | LATIFA E |  |  |  |  |  |  |  |  |  |  |  |  |
| 1132100 |  | FY07-SVT - testing of the prototype (DTCTR R&D) |  | 164d | 2007-06-15 A | 2008-02-19 A | 1132095 | 100% | 2007-06-15 | 2008-02-15 | ELEC ENG [545.03 h]; CONTRB UNIV LBR [479.62 h]; SCIENTIST [261.61 h]; PROCUREMENT<$50K 60 | 60,922.63 | 49,634.63 | 2007-09-28 | 0 | 60828.478295 | ELOUADRHIRI L |  | 1 | 1 | N/A | LATIFA E | 0 | 11288 | 1128800 | 100 |  |  |  |  |  |  |  |  |
| 1132050M |  | FY07-EC -R&D Report (DTCTR R&D) | milestone | 0d | 2007-07-24 A | 2007-07-24 A | 1132050 | 100% | 2007-09-28 | 2007-09-28 |  |  |  | 2007-09-28 |  | 0 | ELOUADRHIRI L |  | 1 | 1 | N/A | LATIFA E |  |  |  |  | 4 |  |  |  |  |  |  |  |
| 1132065M |  | FY07-DC -R&D Report (DTCTR R&D) | milestone | 0d | 2007-09-28 A | 2007-09-28 A | 1132065 | 100% | 2007-10-31 | 2007-10-31 |  |  |  | 2007-09-28 |  | 0 | ELOUADRHIRI L |  | 1 | 1 | N/A | LATIFA E |  |  |  |  | 4 |  |  |  |  |  |  |  |
| 1132075M |  | FY07-FTOF -R&D Report (DTCTR R&D) | milestone | 0d | 2007-09-28 A | 2007-09-28 A | 1132075 | 100% | 2007-10-02 | 2007-10-02 |  |  |  | 2007-09-28 |  | 0 | ELOUADRHIRI L |  | 1 | 1 | N/A | LATIFA E |  |  |  |  | 4 |  |  |  |  |  |  |  |
| 1132090M |  | FY07-CTOF-R&D Report (DTCTR R&D) | milestone | 0d | 2007-09-28 A | 2007-09-28 A | 1132090 | 100% | 2007-10-25 | 2007-10-25 |  |  |  | 2007-09-28 |  | 0 | ELOUADRHIRI L |  | 1 | 1 | N/A | LATIFA E |  |  |  |  | 4 |  |  |  |  |  |  |  |
| 1132820 |  | FY08-DC - Mech protoptyping (DETCTR R&D) |  | 227d | 2007-10-01 A | 2008-08-29 A | 1132065M, 1132854M | 100% |  |  | PROCUREMENT<$50K 60; CONTRB UNIV LBR [144 h]; MECH TECH [144 h]; MECH DES [64 h]; MECH ENG [8 h] | 17,557.16 | 8,858.24 |  | 0 | 17557.157 | ELOUADRHIRI L |  | 1 | 1 | N/A | LATIFA E | 0 | 8698.92 | 869892 | 100 |  |  |  |  |  |  |  |  |
| 1132825 |  | FY08-DC - Elect Prototypng (DETCTR R&D) |  | 227d | 2007-10-01 A | 2008-08-29 A | 1132065M | 100% |  |  | ELEC TECH [32 h]; ELEC ENG [8 h]; PROCUREMENT<$50K 60; ELEC DES [80 h] | 10,529.09 | 5,307.68 |  | 0 | 10529.094 | ELOUADRHIRI L |  | 1 | 1 | N/A | LATIFA E | 0 | 5221.41 | 522141 | 100 |  |  |  |  |  |  |  |  |
| 1132834M |  | FY08-EC -R&D Plans & Initl Sfty Assessmnt (DETCTR R&D) | milestone | 0d | 2007-10-01 A | 2007-10-01 A | 9-080M | 100% | 2007-11-01 | 2007-11-01 |  |  |  |  |  | 0 | ELOUADRHIRI L |  | 1 | 1 | N/A | LATIFA E |  |  |  |  | 6 |  |  |  |  |  |  |  |
| 1132835 |  | FY08-FTOF - Fab Proto (DETCTR R&D) |  | 246d | 2007-10-01 A | 2008-09-26 A | 1132869M | 100% |  |  | PROCUREMENT<$50K 60 | 5,221.41 |  |  | 0 | 5221.414 | ELOUADRHIRI L |  | 1 | 1 | N/A | LATIFA E | 0 | 5221.41 | 522141 | 100 |  |  |  |  |  |  |  |  |
| 1132845 |  | FY08-CTOF - Dsgn of Proto (DETCTR R&D) |  | 153d | 2007-10-01 A | 2008-05-15 A | 1132879M | 100% |  |  |  |  |  |  |  | 0 | ELOUADRHIRI L |  | 1 | 1 | N/A | LATIFA E |  |  |  |  |  |  |  |  |  |  |  |  |
| 1132854M |  | FY08-DC Plans & Initl Sfty Assessmnt (DETCTR R&D) | milestone | 0d | 2007-10-01 A | 2007-10-01 A | 9-080M | 100% | 2007-11-01 | 2007-11-01 |  |  |  |  |  | 0 | ELOUADRHIRI L |  | 1 | 1 | N/A | LATIFA E |  |  |  |  | 6 |  |  |  |  |  |  |  |
| 1132860 |  | FY08-SVT - Prototypng (DETCTR R&D) |  | 227d | 2007-10-01 A | 2008-08-29 A | 1132894M | 100% |  |  | SCIENTIST [12 h]; CONTRB UNIV LBR [144 h]; PROCUREMENT<$50K 60; ELEC ENG [164 h] | 18,755.76 | 10,954.6 |  | 0 | 18755.764 | ELOUADRHIRI L |  | 1 | 1 | N/A | LATIFA E | 0 | 7801.16 | 780116 | 100 |  |  |  |  |  |  |  |  |
| 1132895 |  | FY08-DC- Protoype Testing & Data Analysis (DETCTR R&D) |  | 227d | 2007-10-01 A | 2008-08-29 A | 9-080M, 1132894M | 100% |  |  | CONTRB UNIV LBR [1120 h]; PD UNIV STUDNT [16 h]; MECH ENG [12 h]; VISTNG USERS [280 h]; MECH TECH [40 h]; COMP SCIENT [20 h]; SCIENTIST [160 h] | 18,352.44 | 18,352.44 |  | 0 | 18352.44 | ELOUADRHIRI L |  | 1 | 1 | N/A | LATIFA E |  |  |  |  |  |  | 07-027 |  |  |  |  |  |
| 1132897 |  | FY08-SVT- Protoype Testing & Data Analysis (DETCTR R&D) |  | 227d | 2007-10-01 A | 2008-08-29 A | 9-080M, 1132894M | 100% |  |  | MECH TECH [80 h]; ELEC TECH [16 h]; COMP SCIENT [20 h]; CONTRB UNIV LBR [1188 h]; SCIENTIST [132 h]; VISTNG USERS [788 h] | 26,563.44 | 26,563.44 |  | 0 | 26563.44 | ELOUADRHIRI L |  | 1 | 1 | N/A | LATIFA E |  |  |  |  |  |  |  |  |  |  |  |  |
| 1132840 |  | FY08-FTOF - Testing & Data Analysis from Proto (DETCTR R&D) |  | 236d | 2007-10-15 A | 2008-09-26 A | 1132835 FS-20d | 100% |  |  | PROCUREMENT<$50K 60 | 3,477.5 |  |  | 0 | 3477.503 | ELOUADRHIRI L |  | 1 | 1 | N/A | LATIFA E | 0 | 3477.5 | 347750 | 100 |  |  |  |  |  |  |  |  |
| 1132841 |  | FY08-HTCC - Analysis of Proto (DETCTR R&D) |  | 236d | 2007-10-15 A | 2008-09-26 A | 1132829 FS-20d | 100% |  |  | PD UNIV STUDNT [60 h]; SCIENTIST [8 h]; CONTRB UNIV LBR [32 h] | 1,062.76 | 1,062.76 |  | 0 | 1062.759665 | ELOUADRHIRI L |  | 1 | 1 | N/A | LATIFA E |  |  |  |  |  |  |  |  |  |  |  |  |
| 1132850 |  | FY08-CTOF - Fab Proto (DETCTR R&D) |  | 217d | 2007-10-15 A | 2008-08-29 A | 1132845 | 100% |  |  |  |  |  |  |  | 0 | ELOUADRHIRI L |  | 1 | 1 | N/A | LATIFA E |  |  |  |  |  |  |  |  |  |  |  |  |
| 1132855 |  | FY08-CTOF - Testing of Proto (DETCTR R&D) |  | 237d | 2007-10-15 A | 2008-09-29 A | 1132845, 1132850 | 100% |  |  | TRAVEL | 5,159.5 |  |  | 0 | 5159.5 | ELOUADRHIRI L |  | 1 | 1 | N/A | LATIFA E |  |  |  |  |  |  |  |  |  |  |  |  |
| 1132865 |  | FY08-SVT - Testing of Proto (DETCTR R&D) |  | 237d | 2007-10-15 A | 2008-09-29 A | 1132860 FS-10d | 100% |  |  | SCIENTIST [80 h]; ELEC ENG [164 h]; CONTRB UNIV LBR [144 h]; PROCUREMENT<$50K 60 | 18,666.46 | 15,188.96 |  | 0 | 18666.463 | ELOUADRHIRI L |  | 1 | 1 | N/A | LATIFA E | 0 | 3477.5 | 347750 | 100 |  |  |  |  |  |  |  |  |
| 1132827M |  | FY08-HTCC -R&D Plans & Initl Sfty Assessmnt (DETCTR R&D) | milestone | 0d | 2007-10-16 A | 2007-10-16 A | 9-080M, 1132030M | 100% | 2007-11-01 | 2007-11-01 |  |  |  |  |  | 0 | ELOUADRHIRI L |  | 1 | 1 | N/A | LATIFA E |  |  |  |  | 6 |  |  |  |  |  |  |  |
| 1132829 |  | FY08-HTCC - Testing of Proto (DETCTR R&D) |  | 235d | 2007-10-16 A | 2008-09-26 A | 1132827M | 100% |  |  | CONTRB UNIV LBR [36 h]; SCIENTIST [12 h]; PD UNIV STUDNT [64 h] | 1,349.48 | 1,349.48 |  | 0 | 1349.48 | ELOUADRHIRI L |  | 1 | 1 | N/A | LATIFA E |  |  |  |  |  |  |  | FY08 |  |  |  |  |
| 1132830 |  | FY08-DC - Testing & Analysis of Proto (DETCTR R&D) |  | 235d | 2007-10-16 A | 2008-09-26 A | 1132820, 1132825 | 100% |  |  | ELEC ENG [8 h]; ELEC DES [80 h]; ELEC TECH [32 h] | 5,307.68 | 5,307.68 |  | 0 | 5307.68 | ELOUADRHIRI L |  | 1 | 1 | N/A | LATIFA E |  |  |  |  |  |  |  |  |  |  |  |  |
| 1132869M |  | FY08-FTOF -R&D Plans & Initl Sfty Assessmnt (DETCTR R&D) | milestone | 0d | 2007-10-16 A | 2007-10-16 A | 1132075M | 100% | 2007-11-01 | 2007-11-01 |  |  |  |  |  | 0 | ELOUADRHIRI L |  | 1 | 1 | N/A | LATIFA E |  |  |  |  | 6 |  |  |  |  |  |  |  |
| 1132894M |  | FY08-SVT -R&D Plans & Initl Sfty Assessmnt (DETCTR R&D) | milestone | 0d | 2007-10-16 A | 2007-10-16 A | 1132100M | 100% | 2007-12-03 | 2007-12-03 |  |  |  |  |  | 0 | ELOUADRHIRI L |  | 1 | 1 | N/A | LATIFA E |  |  |  |  | 6 |  |  |  |  |  |  |  |
| 1132100M |  | FY07-SVT -R&D Report (DTCTR R&D) | milestone | 0d | 2008-02-19 A | 2008-02-19 A | 1132100 | 100% | 2008-03-19 | 2008-03-19 |  |  |  | 2007-09-28 |  | 0 | ELOUADRHIRI L |  | 1 | 1 | N/A | LATIFA E |  |  |  |  | 4 |  |  |  |  |  |  |  |
| 1132805 |  | FY08-EC - Smallscale Proto Dsgn (DETCTR R&D) |  | 6d | 2008-03-03 A | 2008-03-10 A | 1132050M, 1132834M | 100% |  |  | PD UNIV STUDNT [60 h]; SCIENTIST [8 h]; CONTRB UNIV LBR [32 h] | 1,062.76 | 1,062.76 |  | 0 | 1062.76 | ELOUADRHIRI L |  | 1 | 1 | N/A | LATIFA E |  |  |  |  |  |  |  |  |  |  |  |  |
| 1132810 |  | FY08-EC - Manufacturing Box & Fixtures for Full Scale Proto (DETCTR R&D) |  | 6d | 2008-03-10 A | 2008-03-17 A | 1132805 | 100% |  |  | PROCUREMENT<$50K 60; MECH ENG [8 h]; MECH DES [12 h]; MECH TECH [80 h] | 12,839.4 | 4,140.48 |  | 0 | 12839.397 | ELOUADRHIRI L |  | 1 | 1 | N/A | LATIFA E | 0 | 8698.92 | 869892 | 100 |  |  |  |  |  |  |  |  |
| 1132815 |  | FY08-EC - Assy & Testing of protoptype (DETCTR R&D) |  | 118d | 2008-03-17 A | 2008-08-29 A | 1132810 | 100% |  |  | VISTNG USERS [156 h]; MECH TECH [104.19 h] | 6,742.57 | 6,742.57 |  | 0 | 6742.568909 | ELOUADRHIRI L |  | 1 | 1 | H | LATIFA E |  |  |  |  |  |  |  |  |  |  |  |  |
| 1132900 |  | SVT Readout (DETCTR R&D) |  | 107d | 2008-04-01 A | 2008-08-29 A | 9-080M FS+120d | 100% |  |  | TRAVEL; ELEC ENG [200 h]; ELEC TECH [280 h]; PROCUREMENT<$50K 60 | 78,348.4 | 23,348.4 |  | 0 | 78348.4 | ELOUADRHIRI L |  | 1 | 1 | U | LATIFA E | 0 | 50000 | 5000000 | 100 |  |  |  |  | 1.1.3.2 | 08-021 |  |  |
| 1132905 |  | CTOF PMT's & Mag Sheild Tests (DETCTR R&D) |  | 139d | 2008-04-01 A | 2008-10-15 A | 9-080M FS+120d | 100% |  |  | PROCUREMENT<$50K 60; SCIENTIST [320 h] | 37,976.79 | 19,976.79 |  | 0 | 37926.4 | ELOUADRHIRI L |  | 1 | 1 | H | LATIFA E | 0 | 18000 | 1800000 | 100 |  |  |  |  | 1.1.3.2 |  | 08-022 |  |
| 1132879M |  | FY08-CTOF -R&D Plans & Initl Sfty Assessmnt (DETCTR R&D) | milestone | 0d | 2008-04-14 A | 2008-04-14 A | 1132090M | 100% | 2008-05-01 | 2008-05-01 |  |  |  |  |  | 0 | ELOUADRHIRI L |  | 1 | 1 | M | LATIFA E |  |  |  |  | 6 |  |  |  |  |  |  |  |
| 1132851M |  | FY08-EC -R&D Report (DETCTR R&D) | milestone | 0d | 2008-09-01 A | 2008-09-01 A | 1132815 | 100% | 2008-10-01 | 2008-10-01 |  |  |  |  |  | 0 | ELOUADRHIRI L |  | 1 | 1 | M | LATIFA E |  |  |  |  | 6 |  |  |  |  |  |  |  |
| 1132875M |  | FY08-FTOF -R&D Report (DETCTR R&D) | milestone | 0d | 2008-09-11 A | 2008-09-11 A | 1132840 | 100% | 2008-10-10 | 2008-10-10 |  |  |  |  |  | 0 | ELOUADRHIRI L |  | 1 | 1 | M | LATIFA E |  |  |  |  | 6 |  | 07-027 |  |  |  |  |  |
| 1132800M |  | FY08-SVT -R&D Report (DETCTR R&D) | milestone | 0d | 2008-09-19 A | 2008-09-19 A | 1132865 | 100% | 2008-10-28 | 2008-10-28 |  |  |  |  |  | 0 | ELOUADRHIRI L |  | 1 | 1 | M | LATIFA E |  |  |  |  | 6 |  | 07-027 |  |  |  |  |  |
| 1132831M |  | FY08-HTCC -R&D Report (DETCTR R&D) | milestone | 0d | 2008-09-26 A | 2008-09-26 A | 1132841 | 100% | 2008-10-13 | 2008-10-13 |  |  |  |  |  | 0 | ELOUADRHIRI L |  | 1 | 1 | M | LATIFA E |  |  |  |  | 6 |  |  |  |  |  |  |  |
| 1132865M |  | FY08-DC -R&D Report (DETCTR R&D) | milestone | 0d | 2008-09-29 A | 2008-09-29 A | 1132830 | 100% | 2008-10-29 | 2008-10-29 |  |  |  |  |  | 0 | ELOUADRHIRI L |  | 1 | 1 | M | LATIFA E |  |  |  |  | 6 |  |  |  |  |  |  |  |
| 1132890M |  | FY08-CTOF-R&D Report (DETCTR R&D) | milestone | 0d | 2008-09-29 A | 2008-09-29 A | 1132855 | 100% | 2008-10-28 | 2008-10-28 |  |  |  |  |  | 0 | ELOUADRHIRI L |  | 1 | 1 | M | LATIFA E |  |  |  |  | 6 |  |  |  |  |  |  |  |
| 1132910 |  | Re-Baseline Actuals Adjustment |  | 1d | 2013-08-30 A | 2013-08-30 A |  | 100% | 2013-09-03 | 2013-09-03 | PROCUREMENT>$50K 69 NO ESCALATION | 32,649.09 |  |  |  | 32649.09 |  |  |  |  |  |  | 0 | 32649.09 | 3264909 | 100 |  |  |  |  |  |  |  | ADJ |

Notes:
- 1132825: Current Status: Added Predecessor "Start of / FY08R&D"
- 1132834M: Current Status: Added Predecessor Start of FY08 R&D
- 1132854M: Current Status: Added Predecessor "Start of / FY08R&D"
- 1132827M: Current Status: Added Predecessor "Start of / FY08R&D"
- 1132869M: Current Status: Added Predecessor "Start of / FY08R&D"
- 1132894M: Current Status: Added Predecessor "Start of / FY08R&D"
- 1132879M: Current Status: Added Predecessor "Start of / FY08R&D"

| ID | WBS | Activity | Type | Duration | Start | Finish | Predecessors | Complete | Planned start | Planned finish | Resources | Cost | Actual cost | Planned FinishUDF | Calculated Remaining Total Cost | MONTHLY EV COST | RESP - Responsibility | STRT%COMP for CM EVM | FNSH%COMP for CM EVM | EVMS Reporting Codes | CAM RESPONSIBLE | Milestone Level | CR 07-027 | Claimed Material Divider | ReBaseline Actuals Adjustment | Remaining Material Cost Based on % Compl | Claimed Material Cost Based on % Complet | Initial Claimed Material Calc | Special | CR 07-016 | CR 09-012 | CR 07-017 | CR 08-013 | WBS ASSIGNMENT | CR 08-028 |
| --- | --- | --- | --- | --- | --- | --- | --- | --- | --- | --- | --- | --- | --- | --- | --- | --- | --- | --- | --- | --- | --- | --- | --- | --- | --- | --- | --- | --- | --- | --- | --- | --- | --- | --- | --- |
|  | 3 | **1.1.3.3 COMPUTING R&D** |  |  |  |  |  |  |  |  |  |  |  |  |  |  |  |  |  |  |  |  |  |  |  |  |  |  |  |  |  |  |  |  |  |
|  | 4 | **1.1.3.4 ELECTRONICS** |  |  |  |  |  |  |  |  |  |  |  |  |  |  |  |  |  |  |  |  |  |  |  |  |  |  |  |  |  |  |  |  |  |
|  | 5 | **1.1.3.5 BEAMLINE** |  |  | 2006-10-02 | 2013-08-30 |  |  |  |  |  |  |  |  |  |  |  |  |  |  |  |  |  |  |  |  |  |  |  |  |  |  |  |  |  |
| 1135015 |  | BL - Conduct rates studies and optimization of the beam line at FDC (BEAMLINE) |  | 183d | 2006-10-02 A | 2007-06-28 A | 9-070M | 100% |  |  | VISTNG USERS [906.02 h]; TRAVEL | 17,657.57 | 15,592.57 | 2007-05-10 | 0 | 17657.567698 | ELOUADRHIRI L | 1 | 1 | N/A | LATIFA E |  |  |  |  |  |  |  |  |  |  |  |  |  |  |
| 1135010 |  | BL - Conduct rates studies and beam line optimization at HTCC (BEAMLINE) |  | 102d | 2007-02-05 A | 2007-06-28 A | 9-070M | 100% |  |  | TRAVEL; VISTNG USERS [906.02 h] | 17,657.57 | 15,592.57 | 2007-04-06 | 0 | 17657.567698 | ELOUADRHIRI L | 1 | 1 | N/A | LATIFA E |  |  |  |  |  |  |  |  |  |  |  |  |  |  |
| 1135020M |  | BL -R&D Report (BEAMLINE) | milestone | 0d | 2007-07-24 A | 2007-07-24 A | 1135010, 1135015 | 100% | 2007-05-11 | 2007-05-11 |  |  |  | 2007-05-11 |  | 0 | ELOUADRHIRI L | 1 | 1 | N/A | LATIFA E | 4 |  |  |  |  |  |  |  |  |  |  |  |  |  |
| 1135025 |  | BL- Rates Studies & Beam Line Optimztn of Forward Detctr |  | 212d | 2007-10-22 A | 2008-08-29 A | 1135020M, 9-080M FS+58d | 100% |  |  | SCIENTIST [544 h]; VISTNG USERS [540 h] | 43,076.48 | 43,076.48 |  | 0 | 43076.48 | ELOUADRHIRI L | 1 | 1 | N/A | LATIFA E |  | 07-027 |  |  |  |  |  |  |  |  |  |  |  |  |
| 1135030 |  | Re-Baseline Actuals Adjustment |  | 1d | 2013-08-30 A | 2013-08-30 A |  | 100% | 2013-09-03 | 2013-09-03 | PROCUREMENT>$50K 69 NO ESCALATION | -11,289.71 |  |  |  |  |  |  |  |  |  |  |  | 100 | ADJ |  |  |  |  |  |  |  |  |  |  |
|  | 6 | **1.1.3.6 INFRASTRUCTURE** |  |  |  |  |  |  |  |  |  |  |  |  |  |  |  |  |  |  |  |  |  |  |  |  |  |  |  |  |  |  |  |  |  |
|  | 4 | **1.1.4 HALL C** |  |  | 2006-10-02 | 2013-08-30 |  |  |  |  |  |  |  |  |  |  |  |  |  |  |  |  |  |  |  |  |  |  |  |  |  |  |  |  |  |
|  | 1 | **1.1.4.1 MAGNET** |  |  | 2006-10-02 | 2013-08-30 |  |  |  |  |  |  |  |  |  |  |  |  |  |  |  |  |  |  |  |  |  |  |  |  |  |  |  |  |  |
| 1141005RKC |  | FY06 Obligations RKC |  | 22d | 2006-10-02 A | 2006-10-31 A | 9-070M | 100% |  |  | PROCUREMENT<$50K 60; PROCUREMENT>$50K 69 | 73,801.42 |  | 2007-03-30 | 0 | 73801.42 | PARKINSON J | 1 | 1 | N/A | HOWARD F |  |  | 100 |  | 0 | 73801.42 | 7380142 | LR |  |  |  |  |  |  |
| 1141020 |  | Cable reshaping and testing for HB and Q1 magnets |  | 205d | 2006-11-01 A | 2007-08-30 A | 9-070M | 100% |  |  | PROCUREMENT<$50K 60 | 49,796 |  | 2007-07-31 | 0 | 49796 | FENKER H | 1 | 1 | N/A | HOWARD F |  |  | 100 |  | 0 | 49796 | 4979600 |  | 07-016 | 09-012 |  |  |  |  |
| 1141015 |  | Build a Test Device to Measure Heat Distribution at the HB Magnet |  | 133d | 2007-02-23 A | 2007-08-30 A | 9-070M | 100% |  |  | PROCUREMENT<$50K 60; MECH ENG [120 h]; TRAVEL; VISTNG USERS [360 h] | 25,855.41 | 13,471.41 | 2007-05-31 | 0 | 25999.663804 | FENKER H | 1 | 1 | N/A | HOWARD F |  |  | 100 |  | 0 | 10320 | 1032000 |  |  |  |  |  |  |  |
| 1141010 |  | Design a scale cross section model of the HB magnet FY 07 |  | 62d | 2007-08-01 A | 2007-10-29 A | 9-070M | 100% | 2007-08-01 | 2007-10-26 | MECH ENG [160 h]; TRAVEL | 13,127.4 | 9,687.4 | 2007-05-31 | 0 | 13113.224 | FENKER H | 1 | 1 | N/A | HOWARD F |  |  |  |  |  |  |  |  |  |  | 07-017 |  |  |  |
| 1141011 |  | Design a scale cross section model of the HB magnet FY 08 |  | 140d | 2007-11-01 A | 2008-05-30 A | 1141010 | 100% |  |  | TRAVEL; MECH ENG [80 h] | 6,722.07 | 4,947.2 | 2007-05-31 | 0 | 6722.068 | FENKER H | 1 | 1 | N/A | HOWARD F |  | 07-027 |  |  |  |  |  |  |  |  | 07-017 |  |  |  |
| 1141013 |  | Prepare Tooling for Coil Winding & Wind Several Subcoils for the HB Magnet |  | 126d | 2008-01-21 A | 2008-07-18 A | 1141010 | 100% | 2008-01-22 | 2008-07-18 | PROCUREMENT<$50K 60 | 18,574.2 |  | 2007-05-31 | 0 | 18574.2 | FENKER H | 1 | 1 | N/A | HOWARD F |  | 07-027 | 100 |  | 0 | 18574.2 | 1857420 |  |  |  | 07-017 | 08-013 |  |  |
| 1141012 |  | Fab 1 full HB Coil & Test Mech, Elect & Insulation Properities @ Room Temp |  | 138d | 2008-07-21 A | 2009-02-11 A | 1141010, 1141013 | 100% |  |  | PROCUREMENT<$50K 60 | 18,698.03 |  | 2007-05-31 | 0 | 18698.028 | FENKER H | 1 | 1 | N/A | HOWARD F |  | 07-027 | 100 |  | 0 | 18698.03 | 1869803 |  |  |  | 07-017 | 08-013 |  |  |
| 1141025 |  | Re-Baseline Actuals Adjustment |  | 1d | 2013-08-30 A | 2013-08-30 A |  | 100% | 2013-09-03 | 2013-09-03 | PROCUREMENT>$50K 69 NO ESCALATION | 48,066.02 |  |  |  | 48066.02 |  |  |  |  |  |  |  | 100 | ADJ | 0 | 48066.02 | 4806602 |  |  |  |  |  |  |  |
|  | 2 | **1.1.4.2 DETECTOR** |  |  | 2006-10-02 | 2013-08-30 |  |  |  |  |  |  |  |  |  |  |  |  |  |  |  |  |  |  |  |  |  |  |  |  |  |  |  |  |  |
| 1141005RKC5 |  | FY06 Obligations RKC |  | 95d | 2006-10-02 A | 2007-02-23 A | 9-070M | 100% |  |  | SUPPLIES & MATERIALS | 6,047.52 |  | 2007-03-30 | 0 | 6047.52 | PARKINSON J | 1 | 1 | N/A | HOWARD F |  |  |  |  |  |  |  | LR |  |  |  |  |  |  |
| 1142020 |  | Continue exploration of alternative calorimeter designs (DTCTR) |  | 345d | 2006-11-01 A | 2008-03-31 A | 9-070M | 100% |  |  | VISTNG USERS [1040 h]; TRAVEL | 19,771.45 | 17,705.45 | 2007-07-17 | 0 | 19923.790933 | FENKER H | 1 | 1 | N/A | HOWARD F |  |  |  |  |  |  |  |  |  |  |  |  |  |  |
| 1142025 |  | In beam test of new prototype quartz hodoscope (DTCTR) |  | 144d | 2007-05-15 A | 2007-12-07 A | 9-070M | 100% |  |  | PD UNIV STUDNT [320 h]; PROCUREMENT<$50K 60; VISTNG USERS [1480 h]; SCIENTIST [400 h]; TRAVEL | 65,493.71 | 52,622.32 | 2007-04-13 | 0 | 67210.123077 | FENKER H | 1 | 1 | N/A | HOWARD F |  |  | 100 |  | 0 | 8260 | 826000 |  |  |  |  |  |  |  |
| 1142030 |  | Test Blocks & PMT's and Map Out Optmal Placement (DTCTR) |  | 107d | 2008-04-01 A | 2008-08-29 A | 9-080M FS+125d | 100% |  |  | VISTNG USERS [880 h] | 14,995.2 | 14,995.2 | 2007-04-13 | 0 | 14995.2 | FENKER H | 1 | 1 | H | HOWARD F |  |  |  |  |  |  |  |  |  |  |  |  | 1.1.4.2 | 08-028 |
| 1142035 |  | Re-Baseline Actuals Adjustment |  | 1d | 2013-08-30 A | 2013-08-30 A |  | 100% | 2013-09-03 | 2013-09-03 | PROCUREMENT>$50K 69 NO ESCALATION | -44,437.94 |  |  |  |  |  |  |  |  |  |  |  | 100 | ADJ |  |  |  |  |  |  |  |  |  |  |

| ID | WBS | Activity | Duration | Start | Finish | Predecessors | Complete | Planned start | Planned finish | Constraint | Resources | Cost | Actual cost | Planned FinishUDF | Remaining Material Cost Based on % Compl | Claimed Material Cost Based on % Complet | Initial Claimed Material Calc | Claimed Material Divider | Calculated Remaining Total Cost | MONTHLY EV COST | RESP - Responsibility | Special | STRT%COMP for CM EVM | FNSH%COMP for CM EVM | CR 07-014 | EVMS Reporting Codes | CAM RESPONSIBLE | LOE Divider | LOE Multiplier | CR 09-012 | CR 07-027 | CR 08-020 | WBS ASSIGNMENT | ReBaseline Actuals Adjustment | CR 10-042 |
| --- | --- | --- | --- | --- | --- | --- | --- | --- | --- | --- | --- | --- | --- | --- | --- | --- | --- | --- | --- | --- | --- | --- | --- | --- | --- | --- | --- | --- | --- | --- | --- | --- | --- | --- | --- |
|  | 3 | **1.1.4.3 COMPUTING** |  |  |  |  |  |  |  |  |  |  |  |  |  |  |  |  |  |  |  |  |  |  |  |  |  |  |  |  |  |  |  |  |  |
|  | 4 | **1.1.4.4 ELECTRONICS** |  |  |  |  |  |  |  |  |  |  |  |  |  |  |  |  |  |  |  |  |  |  |  |  |  |  |  |  |  |  |  |  |  |
|  | 5 | **1.1.4.5 BEAMLINE** |  |  |  |  |  |  |  |  |  |  |  |  |  |  |  |  |  |  |  |  |  |  |  |  |  |  |  |  |  |  |  |  |  |
|  | 6 | **1.1.4.6 INFRASTRUCTURE** |  |  |  |  |  |  |  |  |  |  |  |  |  |  |  |  |  |  |  |  |  |  |  |  |  |  |  |  |  |  |  |  |  |
|  | 5 | **1.1.5 HALL D** |  | 2006-10-02 | 2013-08-30 |  |  |  |  |  |  |  |  |  |  |  |  |  |  |  |  |  |  |  |  |  |  |  |  |  |  |  |  |  |  |
|  | 1 | **1.1.5.1 MAGNET** |  |  |  |  |  |  |  |  |  |  |  |  |  |  |  |  |  |  |  |  |  |  |  |  |  |  |  |  |  |  |  |  |  |
|  | 2 | **1.1.5.2 DETECTOR** |  | 2006-10-02 | 2013-08-30 |  |  |  |  |  |  |  |  |  |  |  |  |  |  |  |  |  |  |  |  |  |  |  |  |  |  |  |  |  |  |
| 1152001RKC |  | FY06 Obligations RKC | 228d | 2006-10-02 A | 2007-08-31 A | 9-070M | 100% |  |  |  | PROCUREMENT<$50K 60; PROCUREMENT>$50K 69; SUPPLIES & MATERIALS; PLABOR | 96,964.66 |  | 2007-03-30 | 0 | 42000.34 | 4200034 | 100 | 0 | 96964.66 | PARKINSON J | LR | 1 | 1 | 07-014 | N/A | ELKE A |  |  |  |  |  |  |  |  |
| 1152015LOE |  | BCAL postdoc (DTCTR) | 79d | 2006-10-02 A | 2007-02-01 A | 9-070M | 100% |  |  |  | PD UNIV STAFF [562.8 h] | 28,156.87 | 28,156.88 | 2007-03-30 |  |  |  |  | 0 | 28156.86915 | CHUDAKOV |  | 1 | 1 | 07-014 | N/A | EUGENE C | 100 | 100 |  |  |  |  |  |  |
| 1152005 |  | Drift chamber prototyping (DTCTR) | 58d | 2006-11-01 A | 2007-02-01 A | 9-070M | 100% |  |  |  | SCIENTIST [904 h]; MECH TECH [910 h]; CONTRB UNIV LBR [261.6 h] | 94,227.56 | 94,227.56 | 2007-09-28 |  |  |  |  | 0 | 94227.56 | CHUDAKOV |  | 1 | 1 | 07-014 | N/A | EUGENE C |  |  | 09-012 |  |  |  |  |  |
| 1152010 |  | BCAL prototyping (DTCTR) | 58d | 2006-11-01 A | 2007-02-01 A | 9-070M | 100% |  |  |  | MECH ENG [335.2 h]; CONTRB UNIV LBR [379.2 h] | 20,701.95 | 20,701.95 | 2007-09-28 |  |  |  |  | 0 | 20701.952 | CHUDAKOV |  | 1 | 1 | 07-014 | N/A | EUGENE C |  |  | 09-012 |  |  |  |  |  |
| 1152020 |  | UPV prototyping (DTCTR) | 324d | 2006-12-01 A | 2008-03-28 A | 9-070M | 100% |  |  |  | PROCUREMENT<$50K 60 | 20,640 |  | 2007-09-28 | 0 | 20640 | 2064000 | 100 | 0 | 20640 | CHUDAKOV |  | 1 | 1 | 07-014 | N/A | EUGENE C |  |  | 09-012 |  |  |  |  |  |
| 1152025 |  | CER prototyping (DTCTR) | 37d | 2006-12-01 A | 2007-02-01 A | 9-070M | 100% | 2006-12-01 | 2007-01-31 |  |  |  |  | 2007-09-28 |  |  |  |  |  | 0 | CHUDAKOV |  | 1 | 1 | 07-014 | N/A | EUGENE C |  |  | 09-012 |  |  |  |  |  |
| 1152005A |  | Drift chamber prototyping (DTCTR) | 168d | 2007-02-01 A | 2007-09-28 A | 1152005 | 100% |  |  | start on or after 2007-02-02 | PROCUREMENT<$50K 60; SCIENTIST [240 h]; MECH DES [520 h]; ELEC DES [440 h]; MECH ENG [1080 h]; PD UNIV STAFF [360 h] | 285,106.1 | 140,626.1 | 2007-09-28 | 0 | 144480 | 14448000 | 100 | 0 | 285092.12182 | CHUDAKOV |  | 1 | 1 | 07-014 | N/A | EUGENE C |  |  | 09-012 |  |  |  |  |  |
| 1152010A |  | BCAL prototyping (DTCTR) | 168d | 2007-02-01 A | 2007-09-28 A | 1152010 | 100% |  |  | start on or after 2007-02-02 | PROCUREMENT<$50K 60 NO ESCALATION FY08; PD UNIV STAFF [680 h]; SCIENTIST [640 h] | 137,490.34 | 73,510.34 | 2007-09-28 | 0 | 63980 | 6398000 | 100 | 0 | 137481.126143 | CHUDAKOV |  | 1 | 1 | 07-014 | N/A | EUGENE C |  |  | 09-012 |  |  |  |  |  |
| 1152015LOEA |  | BCAL postdoc (DTCTR) | 62d | 2007-02-01 A | 2007-05-01 A | 1152015LOE | 100% | 2007-02-01 | 2007-04-30 | start on or after 2007-02-01 |  |  |  | 2007-03-30 |  |  |  |  |  | 0 | CHUDAKOV |  | 1 | 1 | 07-014 | N/A | EUGENE C | 100 | 100 | 09-012 |  |  |  |  |  |
| 1152025A |  | CER prototyping (DTCTR) | 149d | 2007-02-01 A | 2007-08-31 A | 1152025 | 100% |  |  | start on or after 2007-02-01 | PROCUREMENT<$50K 60 | 41,280 |  | 2007-09-28 | 0 | 41280 | 4128000 | 100 | 0 | 41280 | CHUDAKOV |  | 1 | 1 | 07-014 | N/A | EUGENE C |  |  | 09-012 |  |  |  |  |  |
| 1152030 |  | FY08 DC Chamb Prototypng (H-D DETCTR) | 247d | 2007-10-01 A | 2008-09-30 A | 9-080M FS+27d | 100% | 2007-10-01 | 2008-09-29 |  | SCIENTIST [1440 h]; CONTRB UNIV LBR [1160 h] | 89,668.8 | 89,668.8 |  |  |  |  |  | 0 | 89668.8 | CHUDAKOV |  | 1 | 1 |  | N/A | EUGENE C |  |  |  | 07-027 |  |  |  |  |
| 1152035 |  | CDC University Supprt (H-D DETCTR) | 248d | 2007-10-01 A | 2008-09-30 A | 9-080M FS+27d | 100% |  |  |  | CONTRB UNIV LBR [2680 h] |  |  |  |  |  |  |  |  | 0 | CHUDAKOV |  | 1 | 1 |  | H | EUGENE C |  |  |  |  |  |  |  |  |
| 1152945LOE |  | FY08 UPV University Supprt (H-D DETCTR) | 120d | 2007-10-01 A | 2008-03-31 A | 9-080M | 100% |  |  |  | CONTRB UNIV LBR [1120 h] |  |  |  |  |  |  |  |  | 0 | CHUDAKOV |  | 1 | 1 |  | N/A | EUGENE C | 100 | 100 |  |  |  |  |  |  |
| 1152040 |  | BCAL Evaluation & Testing of Module 2 (H-D DETCTR) | 161d | 2007-11-01 A | 2008-06-30 A | 9-080M | 100% |  |  |  | PROCUREMENT<$50K 60; CONTRB UNIV LBR [1840 h] | 87,319.38 |  |  | 0 | 87319.38 | 8731938 | 100 | 0 | 87319.38 | CHUDAKOV |  | 1 | 1 |  | N/A | EUGENE C |  |  |  |  |  |  |  |  |
| 1152055 |  | Invstg common solutn for Gain Monitrng/Calibr Sys in H-D for Calirim's & TOF | 210d | 2008-04-01 A | 2009-02-04 A | 9-080M FS+99d | 100% |  |  |  | SCIENTIST [113.6 h]; PROCUREMENT<$50K 60 | 37,162.14 | 7,162.14 |  | 0 | 30000 | 3000000 | 100 | 0 | 37073.872 | CHUDAKOV |  | 1 | 1 |  | N/A | EUGENE C |  |  | 09-012 |  | 08-020 | 1.1.5.2 |  |  |
| 1152060 |  | Re-Baseline Actuals Adjustment | 1d | 2013-08-30 A | 2013-08-30 A |  | 100% | 2013-09-03 | 2013-09-03 |  | PROCUREMENT>$50K 69 NO ESCALATION | 88,011.48 |  |  | 0 | 88011.48 | 8801148 | 100 |  | 88011.48 |  |  |  |  |  |  |  |  |  |  |  |  |  | ADJ |  |
|  | 3 | **1.1.5.3 COMPUTING** |  |  |  |  |  |  |  |  |  |  |  |  |  |  |  |  |  |  |  |  |  |  |  |  |  |  |  |  |  |  |  |  |  |
|  | 4 | **1.1.5.4 ELECTRONICS** |  | 2006-10-02 | 2013-08-30 |  |  |  |  |  |  |  |  |  |  |  |  |  |  |  |  |  |  |  |  |  |  |  |  |  |  |  |  |  |  |
| 1154001RKC |  | FY06 Obligations RKC | 42d | 2006-10-02 A | 2006-11-30 A | 9-070M | 100% |  |  |  | SUPPLIES & MATERIALS | 7,989.74 |  | 2007-03-30 |  |  |  |  | 0 | 7989.74 | PARKINSON J | LR | 1 | 1 | 07-014 | N/A | ELKE A |  |  |  |  |  |  |  |  |
| 1154010 |  | Trigger development (ELCTRNICS) | 79d | 2006-10-02 A | 2007-02-01 A | 9-070M | 100% |  |  |  |  |  |  | 2007-09-28 |  |  |  |  |  | 0 | CHUDAKOV |  | 1 | 1 | 07-014 | N/A | EUGENE C |  |  | 09-012 |  |  |  |  |  |
| 1154005 |  | FADC development (ELCTRNICS) | 57d | 2006-11-01 A | 2007-02-01 A | 9-070M | 100% | 2006-11-01 | 2007-01-31 |  | SCIENTIST [160.8 h] | 10,321.75 | 10,321.75 | 2007-09-28 |  |  |  |  | 0 | 10321.746556 | CHUDAKOV |  | 1 | 1 | 07-014 | N/A | EUGENE C |  |  | 09-012 |  |  |  |  |  |
| 1154005A |  | FADC development (ELCTRNICS) | 247d | 2007-02-01 A | 2008-01-31 A | 1154005 | 100% |  |  | start on or after 2007-02-02 | PROCUREMENT<$50K 60 | 51,600 |  | 2007-09-28 | 0 | 51600 | 5160000 | 100 | 0 | 51600 | CHUDAKOV |  | 1 | 1 | 07-014 | N/A | EUGENE C |  |  | 09-012 |  |  |  |  |  |
| 1154010A |  | Trigger development (ELCTRNICS) | 149d | 2007-03-01 A | 2007-09-28 A | 1154010 | 100% |  |  | start on or after 2007-02-02 | SCIENTIST [648 h]; VISTNG USERS [1559.2 h]; PROCUREMENT<$50K 60 | 87,378.19 | 66,738.19 | 2007-09-28 | 0 | 20640 | 2064000 | 100 | 0 | 87560.426901 | CHUDAKOV |  | 1 | 1 | 07-014 | N/A | EUGENE C |  |  | 09-012 |  |  |  |  |  |
| 1154020 |  | Develop a Clock Distrbtn Sys to FADC Boards (Electrnc's) | 192d | 2007-10-01 A | 2008-07-11 A | 9-080M | 100% |  |  |  | SCIENTIST [400 h] | 24,908 | 24,908 |  |  |  |  |  | 0 | 24908 | CHUDAKOV |  | 1 | 1 |  | N/A | EUGENE C |  |  |  |  |  |  |  | 10-042 |
| 1154025 |  | Develop Clock Distrbtn for TDCs (Electrnc's) | 227d | 2007-10-01 A | 2008-08-29 A | 9-080M | 100% |  |  |  | SCIENTIST [560 h] | 34,871.2 | 34,871.2 |  |  |  |  |  | 0 | 34871.2 | CHUDAKOV |  | 1 | 1 |  | N/A | EUGENE C |  |  |  | 07-027 |  |  |  | 10-042 |
| 1154035 |  | Collection of Track Counts into Trigger (Electrnc's) | 227d | 2007-10-01 A | 2008-08-29 A | 9-080M | 100% |  |  |  | PROCUREMENT<$50K 60 | 22,361.27 |  |  | 0 | 22361.27 | 2236127 | 100 | 0 | 22361.273 | CHUDAKOV |  | 1 | 1 |  | N/A | EUGENE C |  |  |  |  |  |  |  |  |
| 1154045 |  | Develop Signal Distrbtn to All Crates (Electrnc's) | 194d | 2007-10-01 A | 2008-07-15 A | 9-080M | 100% |  |  |  | PROCUREMENT<$50K 60 | 10,649.21 |  |  | 0 | 10649.21 | 1064921 | 100 | 0 | 10649.208 | CHUDAKOV |  | 1 | 1 |  | N/A | EUGENE C |  |  |  |  |  |  |  |  |
| 1154050 |  | Evaluate Backplane Use of Crates for Dataways, especially FADCs (Electrnc's) | 204d | 2007-11-01 A | 2008-08-29 A | 9-080M | 100% |  |  |  | CONTRB UNIV LBR [560 h] |  |  |  |  |  |  |  |  | 0 | CHUDAKOV |  | 1 | 1 |  | N/A | EUGENE C |  |  |  |  |  |  |  |  |
| 1154015 |  | Logic & HV Supprt (Electrnc's) | 184d | 2007-12-03 A | 2008-08-29 A | 9-080M | 100% |  |  |  | CONTRB UNIV LBR [360 h]; PROCUREMENT<$50K 60 | 21,298.42 |  |  | 0 | 21298.42 | 2129842 | 100 | 0 | 21298.416 | CHUDAKOV |  | 1 | 1 |  | N/A | EUGENE C |  |  |  |  |  |  |  |  |
| 1154030 |  | Collection of Energy Sums into Trigger (Electrnc's) | 149d | 2008-01-31 A | 2008-08-29 A | 1154020, 9-080M | 100% |  |  |  | CONTRB UNIV LBR [600 h] |  |  |  |  |  |  |  |  | 0 | CHUDAKOV |  | 1 | 1 |  | N/A | EUGENE C |  |  |  |  |  |  |  | 10-042 |
| 1154040 |  | Proto Dsgn for Master Trigger (Electrnc's) | 125d | 2008-04-01 A | 2008-09-25 A | 1154035 FS-15d, 9-080M, 1154030 FS-100d | 100% |  |  |  | CONTRB UNIV LBR [600 h] |  |  |  |  |  |  |  |  | 0 | CHUDAKOV |  | 1 | 1 |  | Z | EUGENE C |  |  |  |  |  |  |  |  |
| 1154055 |  | Specify HV & Low Voltage Supplies (Electrnc's) | 61d | 2008-06-30 A | 2008-09-24 A | 1154015 FS-40d | 100% |  |  |  | SCIENTIST [280 h] | 17,435.6 | 17,435.6 |  |  |  |  |  | 0 | 17435.6 | CHUDAKOV |  | 1 | 1 |  | N/A | EUGENE C |  |  |  |  |  |  |  |  |
| 1154060 |  | Specify Discriminators & Logic for DAQ/Trigger Integration (Electrnc's) | 61d | 2008-06-30 A | 2008-09-24 A | 1154015 FS-40d | 100% |  |  |  | SCIENTIST [280 h] | 17,435.6 | 17,435.6 |  |  |  |  |  | 0 | 17435.6 | CHUDAKOV |  | 1 | 1 |  | N/A | EUGENE C |  |  |  |  |  |  |  |  |
| 1154065 |  | Re-Baseline Actuals Adjustment | 1d | 2013-08-30 A | 2013-08-30 A |  | 100% | 2013-09-03 | 2013-09-03 |  | PROCUREMENT>$50K 69 NO ESCALATION | -70,235.81 |  |  |  |  |  | 100 |  |  |  |  |  |  |  |  |  |  |  |  |  |  |  | ADJ |  |

| ID | WBS | Activity | Type | Duration | Start | Finish | Predecessors | Complete | Planned start | Planned finish | Constraint | Resources | Cost | Actual cost | Planned FinishUDF | Calculated Remaining Total Cost | MONTHLY EV COST | RESP - Responsibility | Special | STRT%COMP for CM EVM | FNSH%COMP for CM EVM | CR 07-014 | EVMS Reporting Codes | CAM RESPONSIBLE | CR 09-012 | Remaining Material Cost Based on % Compl | Claimed Material Cost Based on % Complet | Initial Claimed Material Calc | Claimed Material Divider | CR 07-027 | ReBaseline Actuals Adjustment | LOE Divider | LOE Multiplier | Milestone Level |
| --- | --- | --- | --- | --- | --- | --- | --- | --- | --- | --- | --- | --- | --- | --- | --- | --- | --- | --- | --- | --- | --- | --- | --- | --- | --- | --- | --- | --- | --- | --- | --- | --- | --- | --- |
|  | 5 | **1.1.5.5 BEAMLINE** |  |  | 2006-10-02 | 2013-08-30 |  |  |  |  |  |  |  |  |  |  |  |  |  |  |  |  |  |  |  |  |  |  |  |  |  |  |  |  |
| 1155001RKC |  | FY06 Obligations RKC |  | 113d | 2006-10-02 A | 2007-03-21 A | 9-070M | 100% |  |  |  | SUPPLIES & MATERIALS | 24,496.58 |  | 2007-03-30 | 0 | 24496.58 | PARKINSON J | LR | 1 | 1 | 07-014 | N/A | ELKE A |  |  |  |  |  |  |  |  |  |  |
| 1155005 |  | Hodoscope prototyping (BEAMLINE) |  | 79d | 2006-10-02 A | 2007-02-01 A | 9-070M | 100% |  |  |  |  |  |  | 2007-09-28 |  | 0 | CHUDAKOV |  | 1 | 1 | 07-014 | N/A | EUGENE C | 09-012 |  |  |  |  |  |  |  |  |  |
| 1155010 |  | Conduct Diamond studies (BEAMLINE) |  | 13d | 2007-01-15 A | 2007-02-01 A | 9-070M | 100% | 2007-01-16 | 2007-02-01 |  | PD UNIV STUDNT [213.2 h] | 2,121.34 | 2,121.34 | 2007-09-28 | 0 | 2121.34 | CHUDAKOV |  | 1 | 1 | 07-014 | N/A | EUGENE C | 09-012 |  |  |  |  |  |  |  |  |  |
| 1155010A |  | Conduct Diamond studies (BEAMLINE) |  | 394d | 2007-02-02 A | 2008-08-29 A | 1155010 | 100% |  |  |  | PROCUREMENT<$50K 60; PD UNIV STUDNT [580 h] | 24,071.55 | 5,495.55 | 2007-09-28 | 0 | 24122.855353 | CHUDAKOV |  | 1 | 1 | 07-014 | N/A | EUGENE C |  | 0 | 18576 | 1857600 | 100 |  |  |  |  |  |
| 1155005A |  | Hodoscope prototyping (BEAMLINE) |  | 313d | 2007-03-30 A | 2008-07-01 A | 1155005 | 100% |  |  | start on or after 2007-02-02 | PROCUREMENT<$50K 60; PD UNIV STUDNT [3200 h] | 42,542.84 | 30,158.84 | 2007-09-28 | 0 | 42987.33988 | CHUDAKOV |  | 1 | 1 | 07-014 | N/A | EUGENE C | 09-012 | 0 | 12384 | 1238400 | 100 |  |  |  |  |  |
| 1155015 |  | Proto SiPM Readout for Microscope (BL) |  | 204d | 2007-11-01 A | 2008-08-29 A | 9-080M | 100% |  |  |  | PD UNIV STUDNT [880 h] | 8,280.8 | 8,280.8 |  | 0 | 8280.8 | CHUDAKOV |  | 1 | 1 |  | N/A | EUGENE C |  |  |  |  |  | 07-027 |  |  |  |  |
| 1155030 |  | Check Current Sensitivity of Active Collimator Electrnc's (BL) |  | 204d | 2007-11-01 A | 2008-08-29 A | 9-080M | 100% |  |  |  | CONTRB UNIV LBR [720 h] |  |  |  |  | 0 | CHUDAKOV |  | 1 | 1 |  | N/A | EUGENE C |  |  |  |  |  |  |  |  |  |  |
| 1155020 |  | Proto Microscope Mounting Frame (BL) |  | 124d | 2008-04-01 A | 2008-09-24 A | 1155015 | 100% |  |  |  | PD UNIV STUDNT [880 h] | 8,280.8 | 8,280.8 |  | 0 | 8280.8 | CHUDAKOV |  | 1 | 1 |  | N/A | EUGENE C |  |  |  |  |  | 07-027 |  |  |  |  |
| 1155025 |  | Proto Mounting Schemes for Thin Crystals (BL) |  | 129d | 2008-05-01 A | 2008-10-31 A | 9-080M | 100% |  |  |  | PROCUREMENT<$50K 60 | 5,427.79 |  |  | 0 | 5427.794 | CHUDAKOV |  | 1 | 1 |  | N/A | EUGENE C |  | 0 | 5427.79 | 542779 | 100 |  |  |  |  |  |
| 1155035 |  | Re-Baseline Actuals Adjustment |  | 1d | 2013-08-30 A | 2013-08-30 A |  | 100% | 2013-09-03 | 2013-09-03 |  | PROCUREMENT>$50K 69 NO ESCALATION | 154.71 |  |  |  | 154.71 |  |  |  |  |  |  |  |  | 0 | 154.71 | 15471 | 100 |  | ADJ |  |  |  |
|  | 6 | **1.1.5.6 INFRASTRUCTURE** |  |  |  |  |  |  |  |  |  |  |  |  |  |  |  |  |  |  |  |  |  |  |  |  |  |  |  |  |  |  |  |  |
|  | 7 | **1.1.5.7 CRYOGENICS** |  |  |  |  |  |  |  |  |  |  |  |  |  |  |  |  |  |  |  |  |  |  |  |  |  |  |  |  |  |  |  |  |
|  | 6 | **1.1.6 CIVIL** |  |  | 2013-08-30 | 2013-08-30 |  |  |  |  |  |  |  |  |  |  |  |  |  |  |  |  |  |  |  |  |  |  |  |  |  |  |  |  |
|  | 1 | **1.1.6.1 HALL D** |  |  | 2013-08-30 | 2013-08-30 |  |  |  |  |  |  |  |  |  |  |  |  |  |  |  |  |  |  |  |  |  |  |  |  |  |  |  |  |
| 1161000 |  | Re-Baseline Actuals Adjustment |  | 1d | 2013-08-30 A | 2013-08-30 A |  | 100% | 2013-09-03 | 2013-09-03 |  | PROCUREMENT>$50K 69 NO ESCALATION |  |  |  |  | 0 |  |  |  |  |  |  |  |  |  |  |  |  |  | ADJ |  |  |  |
|  | 7 | **1.1.7 R&D PROJECT MANAGEMENT** |  |  | 2006-10-02 | 2013-08-30 |  |  |  |  |  |  |  |  |  |  |  |  |  |  |  |  |  |  |  |  |  |  |  |  |  |  |  |  |
| 117000LOE |  | FY07 R&D Project Management |  | 247d | 2006-10-02 A | 2007-09-28 A | 9-070M | 100% |  |  |  | SR STAFF [148 h]; ADMIN [1760 h]; OFFICE [880 h]; ELEC ENG [360 h]; DIRECTORATE [148 h]; MECH ENG [140 h] | 184,299.09 | 184,299.09 | 2007-09-28 | 0 | 184299.080651 | RODE C |  | 1 | 1 |  | N/A | CLAUS R | 09-012 |  |  |  |  |  |  | 100 | 100 |  |
| 117908LOE |  | FY08 R&D Project Management |  | 248d | 2007-10-01 A | 2008-09-30 A | 117000LOE | 100% |  |  |  | ADMIN [880 h]; OFFICE [880 h]; MECH ENG [352 h]; SR STAFF [598.4 h]; SCIENTIST [246.4 h] | 164,489.95 | 164,489.95 | 2007-09-28 | 0 | 164489.952 | RODE C |  | 1 | 1 |  | E | CLAUS R | 09-012 |  |  |  |  |  |  | 100 | 100 |  |
| 117910 |  | Re-Baseline Actuals Adjustment |  | 1d | 2013-08-30 A | 2013-08-30 A |  | 100% | 2013-09-03 | 2013-09-03 |  | PROCUREMENT>$50K 69 NO ESCALATION | 44,494.58 |  |  |  | 44494.58 |  |  |  |  |  |  |  |  | 0 | 44494.58 | 4449458 | 100 |  | ADJ |  |  |  |
|  | 2 | **1.2 PED** |  |  | 2006-10-02 | 2013-08-30 |  |  |  |  |  |  |  |  |  |  |  |  |  |  |  |  |  |  |  |  |  |  |  |  |  |  |  |  |
|  | 1 | **1.2.1 ACCELERATOR SYSTEMS** |  |  | 2006-10-02 | 2013-08-30 |  |  |  |  |  |  |  |  |  |  |  |  |  |  |  |  |  |  |  |  |  |  |  |  |  |  |  |  |
|  | 1 | **1.2.1.1 CRYOMODULES** |  |  | 2006-10-02 | 2013-08-30 |  |  |  |  |  |  |  |  |  |  |  |  |  |  |  |  |  |  |  |  |  |  |  |  |  |  |  |  |
| 1211005M5 |  | FY07 Internal Intermediate Design and Safety Review | milestone | 0d | 2007-05-21 A | 2007-05-21 A | 111123010M FS+71d | 100% | 2007-06-25 | 2007-06-25 |  |  |  |  | 2006-11-14 |  | 0 | HOGAN J |  | 1 | 1 |  | N/A | JOHN H |  |  |  |  |  | 07-027 |  |  |  | 9 |
| 1211020M |  | FY09 Cvity String Pre-Construction Dsgn & Stfy Review for CM | milestone | 0d | 2008-10-20 A | 2008-10-20 A | 121116020M FS+20d, 121113010M, 121115010M, 121111010M | 100% | 2008-11-03 | 2008-11-03 |  |  |  |  | 2007-02-13 |  | 0 | HOGAN J |  | 1 | 1 |  | M | JOHN H |  |  |  |  |  | 07-027 |  |  |  | 9 |
| 1211020M5 |  | FY09 Space Frame Pre-construction Dsgn & Sfty Review for CM | milestone | 0d | 2008-11-14 A | 2008-11-14 A | 121126020M, 121125020M, 121123010M, 121121010M, 121124020M, 121122010M | 100% | 2008-12-01 | 2008-12-01 |  |  |  |  |  |  | 0 | HOGAN J |  | 1 | 1 |  | M | JOHN H |  |  |  |  |  | 07-027 |  |  |  | 6 |
| 1211020M10 |  | FY09 Cryomodule Pre-construction Dsgn & Sfty Review for CM | milestone | 0d | 2009-10-02 A | 2009-10-02 A | 121131020M, 121137020M, 121132020M, 121133020M, 121135020M, 121136020M, 121134020M, 121138020M | 100% | 2009-11-02 | 2009-11-02 |  |  |  |  | 2007-05-03 |  | 0 | HOGAN J |  | 1 | 1 |  | M | JOHN H |  |  |  |  |  | 07-027 |  |  |  | 9 |
| 1211020M15 |  | FY09 Cryomodule Misc Pre-construction Dsgn & Sfty Review for CM | milestone | 0d | 2010-02-25 A | 2010-02-25 A | 12115005M, 12114005M | 100% | 2010-03-24 | 2010-03-24 |  |  |  |  |  |  | 0 | HOGAN J |  | 1 | 1 |  | M | JOHN H |  |  |  |  |  | 07-027 |  |  |  | 6 |

| ID | WBS | Activity | Type | Duration | Start | Finish | Predecessors | Complete | Planned start | Planned finish | Resources | Cost | Actual cost | Calculated Remaining Total Cost | MONTHLY EV COST | RESP - Responsibility | STRT%COMP for CM EVM | FNSH%COMP for CM EVM | CR 07-027 | EVMS Reporting Codes | CAM RESPONSIBLE | Milestone Level | Remaining Material Cost Based on % Compl | Claimed Material Cost Based on % Complet | Initial Claimed Material Calc | Claimed Material Divider | ReBaseline Actuals Adjustment | CR 10-027 | CR 10-064 | CR 11-051 | CR 12-018 | Planned FinishUDF | CR 09-012 |
| --- | --- | --- | --- | --- | --- | --- | --- | --- | --- | --- | --- | --- | --- | --- | --- | --- | --- | --- | --- | --- | --- | --- | --- | --- | --- | --- | --- | --- | --- | --- | --- | --- | --- |
|  | 1 | **1.2.1.1.1 CAVITY STRING ASSEMBLY** |  |  | 2007-06-04 | 2013-08-30 |  |  |  |  |  |  |  |  |  |  |  |  |  |  |  |  |  |  |  |  |  |  |  |  |  |  |  |
|  | 1 | **1.2.1.1.1.1 CAVITIES** |  |  | 2007-12-03 | 2013-08-30 |  |  |  |  |  |  |  |  |  |  |  |  |  |  |  |  |  |  |  |  |  |  |  |  |  |  |  |
| 121111005 |  | FY08 Final Dsgn Cavity |  | 140d | 2007-12-03 A | 2008-06-30 A | 9-080M FS+30d | 100% | 2007-12-03 | 2008-06-27 | SCIENTIST [40 h]; OFFICE [40 h]; SR STAFF [80 h]; MECH ENG [40 h]; MECH DES [80 h]; ELEC ENG [40 h] | 19,832.4 | 19,832.4 | 0 | 19832.4 | HOGAN J | 1 | 1 | 07-027 | N/A | JOHN H |  |  |  |  |  |  |  |  |  |  |  |  |
| 121111010M |  | FY08 Final Dsgn Comptd for Cavity | milestone | 0d | 2008-06-30 A | 2008-06-30 A | 121111005 | 100% | 2008-07-30 | 2008-07-30 |  |  |  |  | 0 | HOGAN J | 1 | 1 |  | M | JOHN H | 6 |  |  |  |  |  |  |  |  |  |  |  |
| 121111015 |  | Re-Baseline Actuals Adjustment |  | 1d | 2013-08-30 A | 2013-08-30 A |  | 100% | 2013-09-03 | 2013-09-03 | PROCUREMENT>$50K 69 NO ESCALATION | 30,843.82 |  |  | 30843.82 |  |  |  |  |  |  |  | 0 | 30843.82 | 3084382 | 100 | ADJ |  |  |  |  |  |  |
|  | 2 | **1.2.1.1.1.2 NIOBIUM** |  |  |  |  |  |  |  |  |  |  |  |  |  |  |  |  |  |  |  |  |  |  |  |  |  |  |  |  |  |  |  |
|  | 3 | **1.2.1.1.1.3 FUNDAMENTAL POWER COUPLER** |  |  | 2007-12-03 | 2013-08-30 |  |  |  |  |  |  |  |  |  |  |  |  |  |  |  |  |  |  |  |  |  |  |  |  |  |  |  |
| 121113005 |  | FY08 Final Dsgn FPC |  | 140d | 2007-12-03 A | 2008-06-30 A | 9-080M FS+50d | 100% | 2007-12-03 | 2008-06-27 | SCIENTIST [40 h]; OFFICE [40 h]; MECH ENG [80 h]; MECH DES [120 h]; SR STAFF [40 h]; MECH TECH [80 h] | 20,665.2 | 20,665.2 | 0 | 20665.2 | HOGAN J | 1 | 1 | 07-027 | N/A | JOHN H |  |  |  |  |  |  | 10-027 | 10-064 | 11-051 | 12-018F |  |  |
| 121113010M |  | FY08 Final Dsgn Comptd for FPC | milestone | 0d | 2008-06-30 A | 2008-06-30 A | 9-080M, 121113005 | 100% | 2008-07-18 | 2008-07-18 |  |  |  |  | 0 | HOGAN J | 1 | 1 |  | M | JOHN H | 6 |  |  |  |  |  |  |  |  |  |  |  |
| 121113015 |  | Re-Baseline Actuals Adjustment |  | 1d | 2013-08-30 A | 2013-08-30 A |  | 100% | 2013-09-03 | 2013-09-03 | PROCUREMENT>$50K 69 NO ESCALATION | 4,938.62 |  |  | 4938.62 |  |  |  |  |  |  |  | 0 | 4938.62 | 493862 | 100 | ADJ |  |  |  |  |  |  |
|  | 4 | **1.2.1.1.1.4 MISC. CAVITY STRING COMPONENTS** |  |  | 2008-01-14 | 2013-08-30 |  |  |  |  |  |  |  |  |  |  |  |  |  |  |  |  |  |  |  |  |  |  |  |  |  |  |  |
| 121114005 |  | Final Dsgn, Misc Cavity String Components |  | 257d | 2008-01-14 A | 2009-01-26 A | 121111010M | 100% |  |  | MECH DES [40 h]; MECH ENG [40 h] | 4,211.68 | 4,211.68 | 0 | 4306 | HOGAN J | 1 | 1 | 07-027 | N/A | JOHN H |  |  |  |  |  |  |  |  |  |  |  |  |
| 121114010M |  | FY09 Final Dsgn Comptd for Misc Cavity String Components | milestone | 0d | 2009-01-26 A | 2009-01-26 A | 121114005 | 100% | 2009-04-07 | 2009-04-07 |  |  |  |  | 0 | HOGAN J | 1 | 1 | 07-027 | M | JOHN H | 6 |  |  |  |  |  |  |  |  |  |  |  |
| 121114015 |  | Re-Baseline Actuals Adjustment |  | 1d | 2013-08-30 A | 2013-08-30 A |  | 100% | 2013-09-03 | 2013-09-03 | PROCUREMENT>$50K 69 NO ESCALATION | 457.02 |  |  | 457.02 |  |  |  |  |  |  |  | 0 | 457.02 | 45702 | 100 | ADJ |  |  |  |  |  |  |
|  | 5 | **1.2.1.1.1.5 HOM/FIELD PROBES** |  |  | 2007-12-03 | 2013-08-30 |  |  |  |  |  |  |  |  |  |  |  |  |  |  |  |  |  |  |  |  |  |  |  |  |  |  |  |
| 121115005 |  | Final Dsgn HOM/Field Probes |  | 140d | 2007-12-03 A | 2008-06-30 A | 9-080M | 100% | 2007-12-03 | 2008-06-27 | MECH TECH [80 h]; MECH ENG [40 h]; SR STAFF [40 h]; SCIENTIST [40 h]; ELEC ENG [40 h]; MECH DES [80 h] | 17,974.8 | 17,974.8 | 0 | 17974.8 | HOGAN J | 1 | 1 | 07-027 | N/A | JOHN H |  |  |  |  |  |  |  |  |  |  |  |  |
| 121115010M |  | FY08 Final Dsgn Comptd for HOM/Field Probes | milestone | 0d | 2008-06-30 A | 2008-06-30 A | 121115005 | 100% | 2008-07-30 | 2008-07-30 |  |  |  |  | 0 | HOGAN J | 1 | 1 | 07-027 | M | JOHN H | 6 |  |  |  |  |  |  |  |  |  |  |  |
| 121115015 |  | Re-Baseline Actuals Adjustment |  | 1d | 2013-08-30 A | 2013-08-30 A |  | 100% | 2013-09-03 | 2013-09-03 | PROCUREMENT>$50K 69 NO ESCALATION | -17,975.04 |  |  |  |  |  |  |  |  |  |  |  |  |  | 100 | ADJ |  |  |  |  |  |  |
|  | 6 | **1.2.1.1.1.6 HELIUM VESSELS** |  |  | 2007-06-04 | 2013-08-30 |  |  |  |  |  |  |  |  |  |  |  |  |  |  |  |  |  |  |  |  |  |  |  |  |  |  |  |
| 121116005 |  | Design Helium Headers Preliminary (HELIUM VESSLS) |  | 59d | 2007-06-04 A | 2007-08-27 A | 121133005, 121124005 | 100% |  |  | MECH DES [24.36 h]; MECH ENG [48.72 h] | 3,977.3 | 3,977.3 | 0 | 3922.724904 | HOGAN J | 1 | 1 | 07-027 | N/A | JOHN H |  |  |  |  |  |  |  |  |  |  | 2007-02-13 |  |
| 121116010 |  | Design Helium Headers Initial Phase Final Design (HELIUM VESSLS) |  | 39d | 2007-08-06 A | 2007-09-28 A | 121124010, 121133010 | 100% |  |  | MECH DES [10.44 h]; MECH ENG [20.88 h] | 1,681.17 | 1,681.17 | 0 | 1790.0424 | HOGAN J | 1 | 1 | 07-027 | N/A | JOHN H |  |  |  |  |  |  |  |  |  |  | 2007-06-26 |  |
| 121116015 |  | Final Phase Final Dsgn, Helium Headers |  | 205d | 2007-12-03 A | 2008-09-30 A | 9-080M | 100% |  |  | MECH DES [40 h]; SUPPLIES & MATERIALS; MECH ENG [40 h] | 9,805.69 | 4,172.8 | 0 | 9938.885157 | HOGAN J | 1 | 1 | 07-027 | N/A | JOHN H |  |  |  |  |  |  |  |  |  |  |  | 09-012 |
| 121116020M |  | FY09 Final Dsgn Comptd for Helium Headers | milestone | 0d | 2008-09-30 A | 2008-09-30 A | 121116015 | 100% | 2008-10-01 | 2008-10-01 |  |  |  |  | 0 | HOGAN J | 1 | 1 | 07-027 | M | JOHN H | 6 |  |  |  |  |  |  |  |  |  |  |  |
| 121116025 |  | Re-Baseline Actuals Adjustment |  | 1d | 2013-08-30 A | 2013-08-30 A |  | 100% | 2013-09-03 | 2013-09-03 | PROCUREMENT>$50K 69 NO ESCALATION | 37,471.45 |  |  | 37471.45 |  |  |  |  |  |  |  | 0 | 37471.45 | 3747145 | 100 | ADJ |  |  |  |  |  |  |

| ID | WBS | Activity | Type | Duration | Start | Finish | Predecessors | Complete | Planned start | Planned finish | Resources | Cost | Actual cost | Calculated Remaining Total Cost | MONTHLY EV COST | RESP - Responsibility | STRT%COMP for CM EVM | FNSH%COMP for CM EVM | CR 07-027 | EVMS Reporting Codes | CAM RESPONSIBLE | Milestone Level | Claimed Material Divider | ReBaseline Actuals Adjustment | Remaining Material Cost Based on % Compl | Claimed Material Cost Based on % Complet | Initial Claimed Material Calc | CR 08-050 | CR 08-058 | CR 10-027 | CR 10-064 | CR 11-003 | CR 11-012 | CR 11-051 | CR 12-018 | Planned FinishUDF |
| --- | --- | --- | --- | --- | --- | --- | --- | --- | --- | --- | --- | --- | --- | --- | --- | --- | --- | --- | --- | --- | --- | --- | --- | --- | --- | --- | --- | --- | --- | --- | --- | --- | --- | --- | --- | --- |
|  | 2 | **1.2.1.1.2 SPACE FRAME ASSEMBLY** |  |  | 2006-10-02 | 2013-08-30 |  |  |  |  |  |  |  |  |  |  |  |  |  |  |  |  |  |  |  |  |  |  |  |  |  |  |  |  |  |  |
|  | 1 | **1.2.1.1.2.1 TUNER ASSEMBLY** |  |  | 2007-08-06 | 2013-08-30 |  |  |  |  |  |  |  |  |  |  |  |  |  |  |  |  |  |  |  |  |  |  |  |  |  |  |  |  |  |  |
| 121121005 |  | Final Dsgn, Tuner |  | 256d | 2007-08-06 A | 2008-08-15 A | 9-080M | 100% |  |  | MECH ENG [40 h]; MECH DES [80 h]; ELEC ENG [40 h]; MECH TECH [160 h]; SUPPLIES & MATERIALS; SR STAFF [40 h]; OFFICE [40 h]; MSHOP | 36,444.07 | 19,534.76 | 0 | 37162.903647 | HOGAN J | 1 | 1 | 07-027 | N/A | JOHN H |  |  |  |  |  |  |  |  |  |  |  |  |  |  |  |
| 121121010M |  | FY09 Final Dsgn Comptd for Tuner | milestone | 0d | 2008-08-15 A | 2008-08-15 A | 121121005 | 100% | 2008-10-30 | 2008-10-30 |  |  |  |  | 0 | HOGAN J | 1 | 1 | 07-027 | M | JOHN H | 6 |  |  |  |  |  |  |  |  |  |  |  |  |  |  |
| 121121015 |  | Re-Baseline Actuals Adjustment |  | 1d | 2013-08-30 A | 2013-08-30 A |  | 100% | 2013-09-03 | 2013-09-03 | PROCUREMENT>$50K 69 NO ESCALATION | -36,964.7 |  |  |  |  |  |  |  |  |  |  | 100 | ADJ |  |  |  |  |  |  |  |  |  |  |  |  |
|  | 2 | **1.2.1.1.2.2 HEADER ASSEMBLY, SUPPLY & RETURN** |  |  | 2007-08-13 | 2013-08-30 |  |  |  |  |  |  |  |  |  |  |  |  |  |  |  |  |  |  |  |  |  |  |  |  |  |  |  |  |  |  |
| 121122005 |  | Final Dsgn, Header Assy (Supply & Return) |  | 34d | 2007-08-13 A | 2007-09-28 A | 9-090M | 100% |  |  | MECH DES [80 h]; MECH ENG [40 h] | 5,690.89 | 5,690.89 | 0 | 6059.6 | HOGAN J | 1 | 1 | 07-027 | N/A | JOHN H |  |  |  |  |  |  |  |  |  |  |  |  |  |  |  |
| 121122010M |  | FY09 Final Dsgn Comptd for Header Assy (Supply & Return) | milestone | 0d | 2007-09-28 A | 2007-09-28 A | 121122005 | 100% | 2008-10-14 | 2008-10-14 |  |  |  |  | 0 | HOGAN J | 1 | 1 | 07-027 | N/A | JOHN H | 6 |  |  |  |  |  |  |  |  |  |  |  |  |  |  |
| 121122015 |  | Re-Baseline Actuals Adjustment |  | 1d | 2013-08-30 A | 2013-08-30 A |  | 100% | 2013-09-03 | 2013-09-03 | PROCUREMENT>$50K 69 NO ESCALATION | 446.79 |  |  | 446.79 |  |  |  |  |  |  |  | 100 | ADJ | 0 | 446.79 | 44679 |  |  |  |  |  |  |  |  |  |
|  | 3 | **1.2.1.1.2.3 MAGNETIC SHIELD ASSEMBLY** |  |  | 2007-10-01 | 2013-08-30 |  |  |  |  |  |  |  |  |  |  |  |  |  |  |  |  |  |  |  |  |  |  |  |  |  |  |  |  |  |  |
| 121123005 |  | Final Dsgn, Magnetic Shield |  | 248d | 2007-10-01 A | 2008-09-30 A | 9-080M | 100% |  |  | SUPPLIES & MATERIALS; SR STAFF [40 h]; OFFICE [40 h]; MECH ENG [40 h]; MECH DES [80 h] | 22,142.02 | 10,865.6 | 0 | 22488.81849 | HOGAN J | 1 | 1 | 07-027 | N/A | JOHN H |  |  |  |  |  |  |  |  |  |  |  |  |  |  |  |
| 121123010M |  | FY09 Final Dsgn Comptd for Magnetic Shield | milestone | 0d | 2008-09-30 A | 2008-09-30 A | 121123005 | 100% | 2008-10-01 | 2008-10-01 |  |  |  |  | 0 | HOGAN J | 1 | 1 | 07-027 | M | JOHN H | 6 |  |  |  |  |  |  |  |  |  |  |  |  |  |  |
| 131133010XD |  | Prcrmnt Prep for Magnetic Shield |  | 52d | 2008-11-03 A | 2009-01-26 A | 9-090M | 100% |  |  | MECH ENG [13.56 h]; MECH DES [13.56 h] | 1,459.73 | 1,459.73 | 0 | 1459.734 | HOGAN J | 1 | 1 |  | H | JOHN H |  |  |  |  |  |  | 08-050 | 08-058 | 10-027 | 10-064 | 11-003 | 11-012 | 11-051 | 12-018F |  |
| 121123015 |  | Re-Baseline Actuals Adjustment |  | 1d | 2013-08-30 A | 2013-08-30 A |  | 100% | 2013-09-03 | 2013-09-03 | PROCUREMENT>$50K 69 NO ESCALATION | 11,262.88 |  |  | 11262.88 |  |  |  |  |  |  |  | 100 | ADJ | 0 | 11262.88 | 1126288 |  |  |  |  |  |  |  |  |  |
|  | 4 | **1.2.1.1.2.4 THERMAL SHEILD ASSEMBLY, MLI BLANKETS 2&** |  |  | 2007-07-02 | 2013-08-30 |  |  |  |  |  |  |  |  |  |  |  |  |  |  |  |  |  |  |  |  |  |  |  |  |  |  |  |  |  |  |
| 121124005 |  | Design Thermal Shield Preliminary (THRML SHLD) |  | 105d | 2007-07-02 A | 2007-11-30 A | 121131005 | 100% |  |  | MECH DES [48.72 h]; MECH ENG [97.44 h] | 7,946.58 | 7,946.58 | 0 | 7845.449808 | HOGAN J | 1 | 1 | 07-027 | N/A | JOHN H |  |  |  |  |  |  |  |  |  |  |  |  |  |  | 2007-01-03 |
| 121124010 |  | Design Thermal Shield Initial Phase Final Design (THRML SHLD) |  | 16d | 2008-01-17 A | 2008-02-08 A | 121131010, 121135010 | 100% |  |  | MECH ENG [20.88 h]; MECH DES [41.76 h] | 3,065.18 | 3,065.18 | 0 | 3065.184 | HOGAN J | 1 | 1 |  | N/A | JOHN H |  |  |  |  |  |  |  |  |  |  |  |  |  |  | 2007-06-08 |
| 121124015 |  | Dsgn Thermal Shield, Final Phase Final Dsgn |  | 5d | 2008-02-11 A | 2008-02-15 A | 9-090M | 100% |  |  | MECH DES [80 h]; OFFICE [40 h]; MECH ENG [40 h] | 6,879.2 | 6,879.2 | 0 | 7098.8 | HOGAN J | 1 | 1 | 07-027 | N/A | JOHN H |  |  |  |  |  |  |  |  |  |  |  |  |  |  |  |
| 121124020M |  | FY09 Final Dsgn Comptd for Thermal Shield | milestone | 0d | 2008-06-02 A | 2008-06-02 A | 121124015 | 100% | 2008-10-01 | 2008-10-01 |  |  |  |  | 0 | HOGAN J | 1 | 1 |  | M | JOHN H | 6 |  |  |  |  |  |  |  |  |  |  |  |  |  |  |
| 121124025 |  | Re-Baseline Actuals Adjustment |  | 1d | 2013-08-30 A | 2013-08-30 A |  | 100% | 2013-09-03 | 2013-09-03 | PROCUREMENT>$50K 69 NO ESCALATION | 83,809.97 |  |  | 83809.97 |  |  |  |  |  |  |  | 100 | ADJ | 0 | 83809.97 | 8380997 |  |  |  |  |  |  |  |  |  |
|  | 5 | **1.2.1.1.2.5 SEALS & MISC. SPACE FRAME COMPONENTS** |  |  | 2007-06-01 | 2013-08-30 |  |  |  |  |  |  |  |  |  |  |  |  |  |  |  |  |  |  |  |  |  |  |  |  |  |  |  |  |  |  |
| 121125005 |  | Design Seals & Misc Space Frame Preliminary (SEALS) |  | 171d | 2007-06-01 A | 2008-02-13 A | 121134005 FS+120d, 121116005 FS+120d, 121136005 FS+120d | 100% |  |  | MECH ENG [73.08 h]; MECH DES [24.36 h] | 5,496.32 | 5,496.32 | 0 | 5554.08 | HOGAN J | 1 | 1 | 07-027 | N/A | JOHN H |  |  |  |  |  |  |  |  |  |  |  |  |  |  | 2007-03-26 |
| 121125010 |  | Design Seals & Misc Space Frame Initial Phase Final Design (SEALS) |  | 5d | 2008-03-17 A | 2008-03-21 A | 121116010, 121134010, 121136010 | 100% |  |  | MECH ENG [31.32 h]; MECH DES [10.44 h] | 2,380.32 | 2,380.32 | 0 | 2456.2188 | HOGAN J | 1 | 1 |  | N/A | JOHN H |  |  |  |  |  |  |  |  |  |  |  |  |  |  | 2007-07-13 |
| 121125015 |  | Final Phase Final Dsgn, Seals & Misc Space Frame |  | 167d | 2008-03-24 A | 2008-11-14 A | 9-090M | 100% |  |  | MECH TECH [40 h]; MECH ENG [160 h]; ELEC ENG [80 h]; MECH DES [160 h] | 23,385.03 | 23,385.03 | 0 | 23980.4 | HOGAN J | 1 | 1 | 07-027 | N/A | JOHN H |  |  |  |  |  |  |  |  |  |  |  |  |  |  |  |
| 121125020M |  | FY09 Final Dsgn Comptd for Seals & Misc Space Frame | milestone | 0d | 2008-11-14 A | 2008-11-14 A | 121125015 | 100% | 2009-02-11 | 2009-02-11 |  |  |  |  | 0 | HOGAN J | 1 | 1 | 07-027 | M | JOHN H | 6 |  |  |  |  |  |  |  |  |  |  |  |  |  |  |
| 121125025 |  | Re-Baseline Actuals Adjustment |  | 1d | 2013-08-30 A | 2013-08-30 A |  | 100% | 2013-09-03 | 2013-09-03 | PROCUREMENT>$50K 69 NO ESCALATION | 10,008.03 |  |  | 10008.03 |  |  |  |  |  |  |  | 100 | ADJ | 0 | 10008.03 | 1000803 |  |  |  |  |  |  |  |  |  |

Notes:
- 121121005: Corrective Actions: DDM: Added Machine Shop expense / resource ($5290) back into this activity.

| ID | WBS | Activity | Type | Duration | Start | Finish | Predecessors | Complete | Planned start | Planned finish | Resources | Cost | Actual cost | Planned FinishUDF | Calculated Remaining Total Cost | MONTHLY EV COST | RESP - Responsibility | STRT%COMP for CM EVM | FNSH%COMP for CM EVM | CR 07-027 | EVMS Reporting Codes | CAM RESPONSIBLE | Milestone Level | Remaining Material Cost Based on % Compl | Claimed Material Cost Based on % Complet | Initial Claimed Material Calc | Claimed Material Divider | ReBaseline Actuals Adjustment | CR 09-012 |
| --- | --- | --- | --- | --- | --- | --- | --- | --- | --- | --- | --- | --- | --- | --- | --- | --- | --- | --- | --- | --- | --- | --- | --- | --- | --- | --- | --- | --- | --- |
|  | 6 | **1.2.1.1.2.6 SPACE FRAME** |  |  | 2006-10-02 | 2013-08-30 |  |  |  |  |  |  |  |  |  |  |  |  |  |  |  |  |  |  |  |  |  |  |  |
| 121126005 |  | Design Space Frame Preliminary (SPC FRM) |  | 184d | 2006-10-02 A | 2007-06-29 A | 9-070M | 100% |  |  | MECH ENG [146.16 h]; MECH DES [48.72 h] | 11,190.67 | 11,190.67 | 2006-11-08 | 0 | 11190.666261 | HOGAN J | 1 | 1 | 07-027 | N/A | JOHN H |  |  |  |  |  |  |  |
| 121126010 |  | Design Space Frame Initial Phase Final Design (SPC FRM) |  | 61.5d | 2007-09-03 A | 2007-11-30 A | 121138005 | 100% | 2007-09-04 | 2007-11-30 | MECH DES [20.88 h]; MECH ENG [62.64 h] | 4,715.24 | 4,715.24 | 2007-05-21 | 0 | 4760.64 | HOGAN J | 1 | 1 | 07-027 | N/A | JOHN H |  |  |  |  |  |  |  |
| 121126015 |  | Final Phase Final Dsgn, Space Frame |  | 205d | 2007-12-03 A | 2008-09-30 A | 9-090M | 100% |  |  | MECH ENG [160 h]; SR STAFF [40 h]; OFFICE [40 h]; MECH TECH [40 h]; MECH DES [240 h] | 26,651.2 | 26,651.2 |  | 0 | 27502 | HOGAN J | 1 | 1 | 07-027 | N/A | JOHN H |  |  |  |  |  |  |  |
| 121126020M |  | FY09 Final Dsgn Comptd for Space Frame | milestone | 0d | 2008-09-30 A | 2008-09-30 A | 121126015 | 100% | 2008-10-01 | 2008-10-01 |  |  |  |  |  | 0 | HOGAN J | 1 | 1 |  | M | JOHN H | 6 |  |  |  |  |  |  |
| 121126025 |  | Re-Baseline Actuals Adjustment |  | 1d | 2013-08-30 A | 2013-08-30 A |  | 100% | 2013-09-03 | 2013-09-03 | PROCUREMENT>$50K 69 NO ESCALATION | 18,260.82 |  |  |  | 18260.82 |  |  |  |  |  |  |  | 0 | 18260.82 | 1826082 | 100 | ADJ |  |
|  | 3 | **1.2.1.1.3 CRYOMODULE ASSEMBLY** |  |  | 2007-06-04 | 2013-08-30 |  |  |  |  |  |  |  |  |  |  |  |  |  |  |  |  |  |  |  |  |  |  |  |
|  | 1 | **1.2.1.1.3.1 ALIGNMENT FIDUCIALS** |  |  | 2008-01-07 | 2013-08-30 |  |  |  |  |  |  |  |  |  |  |  |  |  |  |  |  |  |  |  |  |  |  |  |
| 121131005 |  | Design Alignment Fiducials Preliminary (ALGNMT FIDUCLS) |  | 62.5d | 2008-01-07 A | 2008-04-04 A | 121132005, 121126005 | 100% |  |  | MECH DES [24.36 h]; MECH ENG [24.36 h] | 2,541.23 | 2,541.23 | 2006-11-14 | 0 | 2462.825232 | HOGAN J | 1 | 1 | 07-027 | N/A | JOHN H |  |  |  |  |  |  |  |
| 121131010 |  | Design Alignment Fiducials Initial Phase Final Design (ALGNMT FIDUCLS) |  | 21.5d | 2008-04-01 A | 2008-04-30 A | 121132010, 121126010 | 100% |  |  | MECH DES [10.44 h]; MECH ENG [10.44 h] | 1,089.1 | 1,089.1 | 2007-05-22 | 0 | 1089.1008 | HOGAN J | 1 | 1 |  | H | JOHN H |  |  |  |  |  |  |  |
| 121131015 |  | Final Phase Final Dsgn, Alignment Fiducials |  | 32d | 2008-08-15 A | 2008-09-30 A | 9-090M | 100% |  |  | MECH DES [40 h]; MECH ENG [40 h] | 4,172.8 | 4,172.8 |  | 0 | 4306 | HOGAN J | 1 | 1 | 07-027 | H | JOHN H |  |  |  |  |  |  | 09-012 |
| 121131020M |  | FY09 Final Dsgn Comptd for Alignment Fiducials | milestone | 0d | 2008-09-30 A | 2008-09-30 A | 121131015 | 100% | 2008-10-01 | 2008-10-01 |  |  |  |  |  | 0 | HOGAN J | 1 | 1 |  | M | JOHN H | 6 |  |  |  |  |  |  |
| 121131025 |  | Re-Baseline Actuals Adjustment |  | 1d | 2013-08-30 A | 2013-08-30 A |  | 100% | 2013-09-03 | 2013-09-03 | PROCUREMENT>$50K 69 NO ESCALATION | -7,857.92 |  |  |  |  |  |  |  |  |  |  |  |  |  |  | 100 | ADJ |  |
|  | 2 | **1.2.1.1.3.2 VACUUM TANK ASSEMBLY** |  |  | 2007-07-02 | 2013-08-30 |  |  |  |  |  |  |  |  |  |  |  |  |  |  |  |  |  |  |  |  |  |  |  |
| 121132005 |  | Design Vacuum Tank Preliminary (VAC TNK ASSMBLY) |  | 63d | 2007-07-02 A | 2007-09-28 A | 9-070M | 100% |  |  | MECH ENG [146.16 h]; MECH DES [48.72 h] | 10,765.25 | 10,765.25 | 2006-11-08 | 0 | 11186.5992 | HOGAN J | 1 | 1 |  | N/A | JOHN H |  |  |  |  |  |  |  |
| 121132010 |  | Design Vacuum Tank Initial Phase Final Design (VAC TNK ASSMBLY) |  | 61.5d | 2007-09-03 A | 2007-11-30 A | 121138005 | 100% | 2007-09-04 | 2007-11-30 | MECH DES [20.88 h]; MECH ENG [62.64 h] | 4,715.24 | 4,715.24 | 2007-05-21 | 0 | 4760.64 | HOGAN J | 1 | 1 | 07-027 | N/A | JOHN H |  |  |  |  |  |  |  |
| 121132015 |  | Final Phase Final Dsgn, Vac Tank |  | 205d | 2007-12-03 A | 2008-09-30 A | 9-080M | 100% |  |  | MECH TECH [40 h]; OFFICE [40 h]; MECH ENG [120 h]; MECH DES [160 h]; SR STAFF [40 h] | 20,779.2 | 20,779.2 |  | 0 | 21442.4 | HOGAN J | 1 | 1 | 07-027 | N/A | JOHN H |  |  |  |  |  |  |  |
| 121132020M |  | FY09 Final Dsgn Comptd for Vac Tank | milestone | 0d | 2008-09-30 A | 2008-09-30 A | 121132015 | 100% | 2008-10-01 | 2008-10-01 |  |  |  |  |  | 0 | HOGAN J | 1 | 1 |  | M | JOHN H | 6 |  |  |  |  |  |  |
| 121132025 |  | Re-Baseline Actuals Adjustment |  | 1d | 2013-08-30 A | 2013-08-30 A |  | 100% | 2013-09-03 | 2013-09-03 | PROCUREMENT>$50K 69 NO ESCALATION | -1,702.58 |  |  |  |  |  |  |  |  |  |  |  |  |  |  | 100 | ADJ |  |
|  | 3 | **1.2.1.1.3.3 END CAN ASSEMBLY** |  |  | 2007-09-10 | 2013-08-30 |  |  |  |  |  |  |  |  |  |  |  |  |  |  |  |  |  |  |  |  |  |  |  |
| 121133010 |  | Design End Cans Initial Phase Final Design (END CAN ASSMBLY) |  | 129d | 2007-09-10 A | 2008-03-21 A | 121131010, 121135010 | 100% |  |  | MECH DES [20.88 h]; MECH ENG [62.64 h] | 4,743.55 | 4,743.55 | 2007-06-08 | 0 | 4760.64 | HOGAN J | 1 | 1 |  | N/A | JOHN H |  |  |  |  |  |  |  |
| 121133005 |  | Design End Cans Preliminary (END CAN ASSMBLY) |  | 14d | 2007-09-10 A | 2007-09-28 A | 121131005 | 100% |  |  | MECH ENG [146.16 h]; MECH DES [48.72 h] | 10,765.25 | 10,765.25 | 2007-01-03 | 0 | 10765.249152 | HOGAN J | 1 | 1 | 07-027 | N/A | JOHN H |  |  |  |  |  |  |  |
| 121133015 |  | Final Phase Final Dsgn, End Cans |  | 172d | 2008-07-14 A | 2009-03-25 A | 9-090M | 100% |  |  | MECH DES [160 h]; MECH ENG [80 h]; SR STAFF [40 h]; ELEC ENG [40 h]; OFFICE [40 h] | 19,641.29 | 19,641.29 |  | 0 | 19841.2 | HOGAN J | 1 | 1 | 07-027 | H | JOHN H |  |  |  |  |  |  |  |
| 121133020M |  | FY09 Final Dsgn Comptd for End Cans | milestone | 0d | 2009-03-25 A | 2009-03-25 A | 121133015 | 100% | 2009-04-24 | 2009-04-24 |  |  |  |  |  | 0 | HOGAN J | 1 | 1 |  | M | JOHN H | 6 |  |  |  |  |  |  |
| 121133025 |  | Re-Baseline Actuals Adjustment |  | 1d | 2013-08-30 A | 2013-08-30 A |  | 100% | 2013-09-03 | 2013-09-03 | PROCUREMENT>$50K 69 NO ESCALATION | 13,565.51 |  |  |  | 13565.51 |  |  |  |  |  |  |  | 0 | 13565.51 | 1356551 | 100 | ADJ |  |

| ID | WBS | Activity | Type | Duration | Start | Finish | Predecessors | Complete | Planned start | Planned finish | Resources | Cost | Actual cost | Planned FinishUDF | Calculated Remaining Total Cost | MONTHLY EV COST | RESP - Responsibility | STRT%COMP for CM EVM | FNSH%COMP for CM EVM | EVMS Reporting Codes | CAM RESPONSIBLE | CR 07-027 | Milestone Level | Remaining Material Cost Based on % Compl | Claimed Material Cost Based on % Complet | Initial Claimed Material Calc | Claimed Material Divider | ReBaseline Actuals Adjustment |
| --- | --- | --- | --- | --- | --- | --- | --- | --- | --- | --- | --- | --- | --- | --- | --- | --- | --- | --- | --- | --- | --- | --- | --- | --- | --- | --- | --- | --- |
|  | 4 | **1.2.1.1.3.4 BEAM LINE ASSEMBLY WITHIN CM** |  |  | 2008-02-06 | 2013-08-30 |  |  |  |  |  |  |  |  |  |  |  |  |  |  |  |  |  |  |  |  |  |  |
| 121134005 |  | Design Transition Beamline Preliminary (BEAMLINE ASSMBLY) |  | 49d | 2008-02-06 A | 2008-04-16 A | 121133005, 121124005 | 100% |  |  | MECH ENG [73.08 h]; MECH DES [48.72 h] | 6,588.9 | 6,588.9 | 2007-02-13 | 0 | 6385.550136 | HOGAN J | 1 | 1 | N/A | JOHN H |  |  |  |  |  |  |  |
| 121134010 |  | Design Transition Beamline Initial Phase Final Design (BEAMLINE ASSMBLY) |  | 31d | 2008-04-07 A | 2008-05-19 A | 121133010, 121124010 | 100% |  |  | MECH DES [20.88 h]; MECH ENG [31.32 h] | 2,823.81 | 2,823.81 | 2007-06-26 | 0 | 2823.8112 | HOGAN J | 1 | 1 | H | JOHN H |  |  |  |  |  |  |  |
| 121134015 |  | Final Phase Final Dsgn, Transition BL in CM |  | 107d | 2008-05-20 A | 2008-10-20 A | 9-080M | 100% |  |  | MECH ENG [80 h]; MECH DES [120 h]; SUPPLIES & MATERIALS; MECH TECH [80 h]; ELEC ENG [80 h] | 29,512.3 | 18,235.88 |  | 0 | 30016.41849 | HOGAN J | 1 | 1 | H | JOHN H | 07-027 |  |  |  |  |  |  |
| 121134020M |  | FY09 Final Dsgn Comptd for Transition BL in CM | milestone | 0d | 2008-10-20 A | 2008-10-20 A | 121134015 | 100% | 2008-12-01 | 2008-12-01 |  |  |  |  |  | 0 | HOGAN J | 1 | 1 | M | JOHN H |  | 6 |  |  |  |  |  |
| 121134025 |  | Re-Baseline Actuals Adjustment |  | 1d | 2013-08-30 A | 2013-08-30 A |  | 100% | 2013-09-03 | 2013-09-03 | PROCUREMENT>$50K 69 NO ESCALATION | 39,223.87 |  |  |  | 39223.87 |  |  |  |  |  |  |  | 0 | 39223.87 | 3922387 | 100 | ADJ |
|  | 5 | **1.2.1.1.3.5 STANDS** |  |  | 2008-07-01 | 2013-08-30 |  |  |  |  |  |  |  |  |  |  |  |  |  |  |  |  |  |  |  |  |  |  |
| 121135005 |  | Design Stands Preliminary (STANDS) |  | 1d | 2008-07-01 A | 2008-07-01 A | 121132005, 121126005 | 100% |  |  | MECH DES [24.36 h]; MECH ENG [24.36 h] | 2,541.23 | 2,541.23 | 2006-11-09 | 0 | 2462.825232 | HOGAN J | 1 | 1 | H | JOHN H |  |  |  |  |  |  |  |
| 121135010 |  | Design Stands Initial Phase Final Design (STANDS) |  | 2d | 2008-07-01 A | 2008-07-02 A | 121126010, 121132010, 121135005 | 100% |  |  | MECH DES [10.44 h]; MECH ENG [10.44 h] | 1,089.1 | 1,089.1 | 2007-05-21 | 0 | 1089.1008 | HOGAN J | 1 | 1 | H | JOHN H |  |  |  |  |  |  |  |
| 121135015 |  | Final Phase Final Dsgn, Stands |  | 32d | 2008-08-15 A | 2008-09-30 A | 9-090M | 100% |  |  | MECH DES [40 h]; MECH ENG [40 h] | 4,172.8 | 4,172.8 |  | 0 | 4306 | HOGAN J | 1 | 1 | H | JOHN H | 07-027 |  |  |  |  |  |  |
| 121135020M |  | FY09 Final Dsgn Comptd for Stands | milestone | 0d | 2008-09-30 A | 2008-09-30 A | 121135015 | 100% | 2008-10-01 | 2008-10-01 |  |  |  |  |  | 0 | HOGAN J | 1 | 1 | M | JOHN H |  | 6 |  |  |  |  |  |
| 121135025 |  | Re-Baseline Actuals Adjustment |  | 1d | 2013-08-30 A | 2013-08-30 A |  | 100% | 2013-09-03 | 2013-09-03 | PROCUREMENT>$50K 69 NO ESCALATION | -7,857.91 |  |  |  |  |  |  |  |  |  |  |  |  |  |  | 100 | ADJ |
|  | 6 | **1.2.1.1.3.6 WIRING INCL HOM & FP CABLES** |  |  | 2008-02-06 | 2013-08-30 |  |  |  |  |  |  |  |  |  |  |  |  |  |  |  |  |  |  |  |  |  |  |
| 121136005 |  | Design Wiring Preliminary (WIRING) |  | 7d | 2008-02-06 A | 2008-02-15 A | 121133005, 121124005 | 100% |  |  | MECH DES [24.36 h]; MECH ENG [48.72 h] | 4,047.65 | 4,047.65 | 2007-02-13 | 0 | 3922.724904 | HOGAN J | 1 | 1 | N/A | JOHN H | 07-027 |  |  |  |  |  |  |
| 121136015 |  | Final Phase Final Dsgn, Wiring |  | 155d | 2008-04-14 A | 2008-11-20 A | 9-080M | 100% | 2008-04-14 | 2008-11-19 | ELEC DES [120 h]; MECH ENG [40 h]; MECH DES [160 h]; SUPPLIES & MATERIALS; ELEC ENG [80 h] | 25,374.17 | 19,741.28 |  | 0 | 25855.685157 | HOGAN J | 1 | 1 | H | JOHN H | 07-027 |  |  |  |  |  |  |
| 121136010 |  | Design Wiring Initial Phase Final Design (WIRING) |  | 11d | 2008-04-16 A | 2008-04-30 A | 121133010, 121124010 | 100% |  |  | MECH DES [10.44 h]; MECH ENG [20.88 h] | 1,734.71 | 1,734.71 | 2007-06-26 | 0 | 1734.7104 | HOGAN J | 1 | 1 | H | JOHN H |  |  |  |  |  |  |  |
| 121136020M |  | FY09 Final Dsgn Comptd for Wiring | milestone | 0d | 2008-11-20 A | 2008-11-20 A | 121136015 | 100% | 2009-02-20 | 2009-02-20 |  |  |  |  |  | 0 | HOGAN J | 1 | 1 | M | JOHN H |  | 6 |  |  |  |  |  |
| 121136025 |  | Re-Baseline Actuals Adjustment |  | 1d | 2013-08-30 A | 2013-08-30 A |  | 100% | 2013-09-03 | 2013-09-03 | PROCUREMENT>$50K 69 NO ESCALATION | -29,255.43 |  |  |  |  |  |  |  |  |  |  |  |  |  |  | 100 | ADJ |
|  | 7 | **1.2.1.1.3.7 FEEDTHROUGHS INCL WARM/COLD HOM/FP** |  |  | 2007-06-04 | 2013-08-30 |  |  |  |  |  |  |  |  |  |  |  |  |  |  |  |  |  |  |  |  |  |  |
| 121137005 |  | Design Feedthroughs Preliminary (FEEDTHRU) |  | 19d | 2007-06-04 A | 2007-06-29 A | 121134005 FS+120d, 121136005 FS+120d, 121116005 FS+120d | 100% |  |  | MECH ENG [48.72 h]; MECH DES [24.36 h] | 4,087.85 | 4,087.85 | 2007-03-26 | 0 | 4047.6576 | HOGAN J | 1 | 1 | N/A | JOHN H | 07-027 |  |  |  |  |  |  |
| 121137010 |  | Design Feedthroughs Initial Phase Final Design (FEEDTHRU) |  | 9d | 2008-02-04 A | 2008-02-14 A | 121136010, 121134010, 121116010 | 100% |  |  | MECH ENG [20.88 h]; MECH DES [10.44 h] | 1,734.71 | 1,734.71 | 2007-07-13 | 0 | 1790.0424 | HOGAN J | 1 | 1 | N/A | JOHN H |  |  |  |  |  |  |  |
| 121137015 |  | Final Phase Final Dsgn, Feedthroughs |  | 214d | 2008-03-17 A | 2009-01-26 A | 9-080M | 100% |  |  | ELEC ENG [40 h]; ELEC TECH [40 h]; MECH ENG [120 h]; MECH DES [320 h]; MECH TECH [160 h]; SUPPLIES & MATERIALS | 54,236.78 | 31,683.94 |  | 0 | 54886.83698 | HOGAN J | 1 | 1 | N/A | JOHN H | 07-027 |  |  |  |  |  |  |
| 121137020M |  | FY09 Final Dsgn Comptd for Feedthroughs | milestone | 0d | 2009-01-26 A | 2009-01-26 A | 121137015 | 100% | 2009-04-15 | 2009-04-15 |  |  |  |  |  | 0 | HOGAN J | 1 | 1 | M | JOHN H |  | 6 |  |  |  |  |  |
| 121137025 |  | Re-Baseline Actuals Adjustment |  | 1d | 2013-08-30 A | 2013-08-30 A |  | 100% | 2013-09-03 | 2013-09-03 | PROCUREMENT>$50K 69 NO ESCALATION | 6,586.39 |  |  |  | 6586.39 |  |  |  |  |  |  |  | 0 | 6586.39 | 658639 | 100 | ADJ |

| ID | WBS | Activity | Type | Duration | Start | Finish | Predecessors | Complete | Planned start | Planned finish | Resources | Cost | Actual cost | Planned FinishUDF | Calculated Remaining Total Cost | MONTHLY EV COST | RESP - Responsibility | STRT%COMP for CM EVM | FNSH%COMP for CM EVM | EVMS Reporting Codes | CAM RESPONSIBLE | CR 07-027 | CR 09-012 | WBS ASSIGNMENT | CR 09-016 | Milestone Level | Claimed Material Divider | ReBaseline Actuals Adjustment | LOE Divider | LOE Multiplier | Profile change |
| --- | --- | --- | --- | --- | --- | --- | --- | --- | --- | --- | --- | --- | --- | --- | --- | --- | --- | --- | --- | --- | --- | --- | --- | --- | --- | --- | --- | --- | --- | --- | --- |
|  | 8 | **1.2.1.1.3.8 HOM LOADS** |  |  | 2008-02-04 | 2013-08-30 |  |  |  |  |  |  |  |  |  |  |  |  |  |  |  |  |  |  |  |  |  |  |  |  |  |
| 121138005 |  | Design HOM Loads Preliminary (HOM LOADS) |  | 6d | 2008-02-04 A | 2008-02-12 A | 121125005, 121137005 | 100% |  |  | MECH ENG [24.36 h]; MECH DES [24.36 h] | 2,541.23 | 2,541.23 | 2007-05-03 | 0 | 2541.2352 | HOGAN J | 1 | 1 | N/A | JOHN H |  |  |  |  |  |  |  |  |  |  |
| 121138010 |  | Design HOM Loads Initial Phase Final Design (HOM LOADS) |  | 10d | 2008-03-10 A | 2008-03-21 A | 121125010, 121137010 | 100% |  |  | MECH DES [10.44 h]; MECH ENG [10.44 h] | 1,089.1 | 1,089.1 | 2007-07-31 | 0 | 1123.866 | HOGAN J | 1 | 1 | N/A | JOHN H |  |  |  |  |  |  |  |  |  |  |
| 121138015 |  | Final Phase Final Dsgn, HOM Loads |  | 289d | 2008-05-20 A | 2009-07-17 A | 121138010 | 100% |  |  | MECH ENG [160 h]; MECH DES [160 h]; MECH TECH [160 h]; ELEC ENG [80 h]; SCIENTIST [80 h]; SUPPLIES & MATERIALS; SR STAFF [40 h] | 60,262.44 | 37,709.6 |  | 0 | 60641.63698 | HOGAN J | 1 | 1 | H | JOHN H | 07-027 | 09-012 |  |  |  |  |  |  |  |  |
| 121138025 |  | Computational Analysis |  | 80d | 2009-03-16 A | 2009-07-07 A | 11114070M FS+165d | 100% |  |  | SCIENTIST [40 h] | 2,570.4 | 2,570.4 |  | 0 | 2570.4 | HOGAN J | 1 | 1 | H | JOHN H |  |  | 1.2.1.1.3.8 | 09-016 |  |  |  |  |  |  |
| 121138030 |  | Fabricate Test Hardware |  | 5d | 2009-03-23 A | 2009-03-30 A | 121138025 | 100% |  |  | MECH ENG [40 h]; MECH DES [40 h]; MECH TECH [80 h]; SUPPLIES & MATERIALS | 11,542 | 7,542 |  | 0 | 11542 | HOGAN J | 1 | 1 | H | JOHN H |  |  | 1.2.1.1.3.8 | 09-016 |  |  |  |  |  |  |
| 121138035 |  | Measure (First) HOM Damping in VTA |  | 18d | 2009-03-25 A | 2009-04-20 A | 121138030 | 100% |  |  | ELEC TECH [120 h]; MECH TECH [120 h]; COMP SCIENT [40 h]; SCIENTIST [80 h]; ELEC ENG [80 h] | 22,342 | 22,342 |  | 0 | 22342 | HOGAN J | 1 | 1 | H | JOHN H |  |  | 1.2.1.1.3.8 | 09-016 |  |  |  |  |  |  |
| 121138040 |  | Evaluate (First) Measurement results |  | 47d | 2009-03-25 A | 2009-05-29 A | 121138035 | 100% |  |  | SR STAFF [40 h]; SCIENTIST [80 h]; ELEC ENG [40 h] | 11,823.6 | 11,823.6 |  | 0 | 11823.6 | HOGAN J | 1 | 1 | H | JOHN H |  |  | 1.2.1.1.3.8 | 09-016 |  |  |  |  |  |  |
| 121138045 |  | Modify Test Hardware |  | 16d | 2009-06-01 A | 2009-06-22 A | 121138040 | 100% |  |  | MECH TECH [80 h]; MECH ENG [40 h]; MECH DES [40 h]; SUPPLIES & MATERIALS | 10,542 | 7,542 |  | 0 | 10542 | HOGAN J | 1 | 1 | H | JOHN H |  |  | 1.2.1.1.3.8 | 09-016 |  |  |  |  |  |  |
| 121138050 |  | Measure (Second) HOM Damping in VTA |  | 16d | 2009-06-01 A | 2009-06-22 A | 121138045 | 100% |  |  | SCIENTIST [80 h]; ELEC ENG [80 h]; ELEC TECH [120 h]; MECH TECH [120 h]; COMP SCIENT [40 h] | 22,342 | 22,342 |  | 0 | 22342 | HOGAN J | 1 | 1 | H | JOHN H |  |  | 1.2.1.1.3.8 | 09-016 |  |  |  |  |  |  |
| 121138055 |  | Evaluate (Second) Measurement results |  | 16d | 2009-06-01 A | 2009-06-22 A | 121138050 | 100% |  |  | ELEC ENG [40 h]; SR STAFF [40 h] | 6,682.8 | 6,682.8 |  | 0 | 6682.8 | HOGAN J | 1 | 1 | H | JOHN H |  |  | 1.2.1.1.3.8 | 09-016 |  |  |  |  |  |  |
| 121138060 |  | Document HOM damping results and final |  | 16d | 2009-06-01 A | 2009-06-22 A | 121138055 | 100% |  |  | SCIENTIST [40 h] | 2,570.4 | 2,570.4 |  | 0 | 2570.4 | HOGAN J | 1 | 1 | H | JOHN H |  |  | 1.2.1.1.3.8 | 09-016 |  |  |  |  |  |  |
| 121138020M |  | FY09 Final Dsgn Comptd for HOM Loads | milestone | 0d | 2009-07-17 A | 2009-07-17 A | 121138015 | 100% | 2009-09-17 | 2009-09-17 |  |  |  |  |  | 0 | HOGAN J | 1 | 1 | M | JOHN H |  |  |  |  | 6 |  |  |  |  |  |
| 121138065 |  | Re-Baseline Actuals Adjustment |  | 1d | 2013-08-30 A | 2013-08-30 A |  | 100% | 2013-09-03 | 2013-09-03 | PROCUREMENT>$50K 69 NO ESCALATION | -92,544.23 |  |  |  |  |  |  |  |  |  |  |  |  |  |  | 100 | ADJ |  |  |  |
|  | 4 | **1.2.1.1.4 INSTALLATION & ASSEMBLY TOOLING** |  |  | 2008-07-14 | 2013-08-30 |  |  |  |  |  |  |  |  |  |  |  |  |  |  |  |  |  |  |  |  |  |  |  |  |  |
| 12114000 |  | Final Dsgn of Installtn & Assy Tooling |  | 400d | 2008-07-14 A | 2010-02-25 A | 9-090M | 100% |  |  | MECH ENG [160 h]; MECH DES [320 h]; SUPPLIES & MATERIALS; MECH TECH [80 h] | 50,118.81 | 27,565.97 |  | 0 | 50027.23698 | HOGAN J | 1 | 1 | H | JOHN H | 07-027 | 09-012 |  |  |  |  |  |  |  |  |
| 12114005M |  | FY09 Final Dsgn Comptd for Installtn & Assy Tooling | milestone | 0d | 2010-02-25 A | 2010-02-25 A | 12114000 | 100% | 2010-03-24 | 2010-03-24 |  |  |  |  |  | 0 | HOGAN J | 1 | 1 | M | JOHN H | 07-027 |  |  |  | 6 |  |  |  |  |  |
| 12114010 |  | Re-Baseline Actuals Adjustment |  | 1d | 2013-08-30 A | 2013-08-30 A |  | 100% | 2013-09-03 | 2013-09-03 | PROCUREMENT>$50K 69 NO ESCALATION | -19,123.75 |  |  |  |  |  |  |  |  |  |  |  |  |  |  | 100 | ADJ |  |  |  |
|  | 5 | **1.2.1.1.5 CRYOMODULE TEST INSTRUMENTATION & INTERLOCKS** |  |  | 2008-07-14 | 2013-08-30 |  |  |  |  |  |  |  |  |  |  |  |  |  |  |  |  |  |  |  |  |  |  |  |  |  |
| 12115000 |  | Final Dsgn of Instrmenttn & Interlocks |  | 400d | 2008-07-14 A | 2010-02-25 A | 9-090M | 100% |  |  | SUPPLIES & MATERIALS; ELEC ENG [160 h]; ELEC TECH [80 h]; MECH DES [40 h]; ELEC DES [160 h]; MECH TECH [80 h] | 37,198.29 | 25,921.87 |  | 0 | 37113.21849 | HOGAN J | 1 | 1 | H | JOHN H | 07-027 |  |  |  |  |  |  |  |  |  |
| 12115005M |  | FY09 Final Dsgn Comptd for Instrmenttn & Interlocks | milestone | 0d | 2010-02-25 A | 2010-02-25 A | 12115000 | 100% | 2010-03-24 | 2010-03-24 |  |  |  |  |  | 0 | HOGAN J | 1 | 1 | M | JOHN H |  |  |  |  | 6 |  |  |  |  |  |
| 12115010 |  | Re-Baseline Actuals Adjustment |  | 1d | 2013-08-30 A | 2013-08-30 A |  | 100% | 2013-09-03 | 2013-09-03 | PROCUREMENT>$50K 69 NO ESCALATION | -10,715.98 |  |  |  |  |  |  |  |  |  |  |  |  |  |  | 100 | ADJ |  |  |  |
|  | 2 | **1.2.1.2 POWER SYSTEMS** |  |  | 2006-10-02 | 2013-08-30 |  |  |  |  |  |  |  |  |  |  |  |  |  |  |  |  |  |  |  |  |  |  |  |  |  |
|  | 1 | **1.2.1.2.1 RF** |  |  | 2006-10-02 | 2013-08-30 |  |  |  |  |  |  |  |  |  |  |  |  |  |  |  |  |  |  |  |  |  |  |  |  |  |
|  | 1 | **1.2.1.2.1.1 POWER** |  |  | 2006-10-02 | 2013-08-30 |  |  |  |  |  |  |  |  |  |  |  |  |  |  |  |  |  |  |  |  |  |  |  |  |  |
|  | 1 | **1.2.1.2.1.1.1 KLYSTRONS** |  |  | 2006-10-02 | 2013-08-30 |  |  |  |  |  |  |  |  |  |  |  |  |  |  |  |  |  |  |  |  |  |  |  |  |  |
| 1212111000M |  | Start Klystron PED effort (KLYSTRONS) | milestone | 0d | 2006-10-02 A | 2006-10-02 A | 9-070M | 100% |  |  |  |  |  | 2006-10-02 |  | 0 | NELSON R | 1 | 1 | N/A | BILL M |  |  |  |  | 9 |  |  |  |  |  |
| 1212111007LOE |  | FY07 Project administration (KLYSTRONS) |  | 247d | 2006-10-02 A | 2007-09-28 A | 1212111000M | 100% |  |  | SR STAFF [382.8 h] | 38,132.05 | 38,132.05 | 2007-09-28 | 0 | 38132.0478 | NELSON R | 1 | 1 | N/A | BILL M |  | 09-012 |  |  |  |  |  | 100 | 100 |  |
| 1212111010 |  | Refine klystron specifications w/driver (KLYSTRONS) |  | 120d | 2006-10-02 A | 2007-03-30 A | 1212111000M | 100% |  |  | ELEC DES [69.6 h]; ELEC ENG [52.2 h] | 6,579.46 | 6,579.46 | 2007-03-02 | 0 | 6579.462 | NELSON R | 1 | 1 | N/A | BILL M |  |  |  |  |  |  |  |  |  |  |
| 1212111020 |  | Update budgetary pricing through vendor requests (KLYSTRONS) |  | 28d | 2007-03-15 A | 2007-04-23 A | 1212111040, 1212111015M, 1212111035M | 100% |  |  | ELEC ENG [10.44 h]; TRAVEL | 4,792.21 | 666.21 | 2007-05-11 | 0 | 4774.5328 | NELSON R | 1 | 1 | N/A | BILL M |  |  |  |  |  |  |  |  |  |  |
| 1212111015M |  | Specifications revision complete (KLYSTRONS) | milestone | 0d | 2007-04-02 A | 2007-04-02 A | 1212111010 | 100% | 2007-03-02 | 2007-03-02 |  |  |  | 2007-03-02 |  | 0 | NELSON R | 1 | 1 | N/A | BILL M |  |  |  |  | 9 |  |  |  |  |  |
| 1212111030 |  | Internal design & safety review of klystron specifications (KLYSTRONS) |  | 32d | 2007-04-09 A | 2007-05-22 A | 1212111015M | 100% |  |  | TRAVEL; ELEC ENG [17.4 h] | 3,144.89 | 1,080.89 | 2007-03-16 | 0 | 3213.618 | NELSON R | 1 | 1 | N/A | BILL M |  |  |  |  |  |  |  |  |  |  |
| 1212111045 |  | Revise costbook based on new pricing (KLYSTRONS) |  | 11d | 2007-04-09 A | 2007-04-23 A | 1212111025M | 100% |  |  | ELEC ENG [17.4 h] | 1,080.89 | 1,080.89 | 2007-05-18 | 0 | 1080.888 | NELSON R | 1 | 1 | N/A | BILL M |  |  |  |  |  |  |  |  |  |  |
| 1212111025M |  | Budgetary pricing received from vendors (KLYSTRONS) | milestone | 0d | 2007-04-23 A | 2007-04-23 A | 1212111020 | 100% | 2007-05-11 | 2007-05-11 |  |  |  | 2007-05-11 |  | 0 | NELSON R | 1 | 1 | N/A | BILL M |  |  |  |  | 9 |  |  |  |  |  |
| 1212111035M |  | Preliminary internal design & safety review complete (KLYSTRONS) | milestone | 0d | 2007-05-22 A | 2007-05-22 A | 1212111030 | 100% | 2007-03-16 | 2007-03-16 |  |  |  | 2007-03-16 |  | 0 | NELSON R | 1 | 1 | N/A | BILL M |  |  |  |  | 9 |  |  |  |  |  |
| 1212111040 |  | Revise preliminary klystron specifications per design & safety review (KLYSTRONS) |  | 26d | 2007-05-23 A | 2007-06-28 A | 1212111035M | 100% |  |  | ELEC ENG [6.96 h] | 432.36 | 432.36 | 2007-04-13 | 0 | 446.1012 | NELSON R | 1 | 1 | N/A | BILL M |  |  |  |  |  |  |  |  |  |  |
| 1212111055 |  | Begin final design (FY07 continuing into FY08) (KLYSTRONS) |  | 58d | 2007-05-28 A | 2007-08-20 A | 1212111050M | 100% | 2007-05-29 | 2007-08-20 | ELEC ENG [34.8 h] | 2,124.97 | 2,124.97 | 2007-09-28 | 0 | 2118.78113 | NELSON R | 1 | 1 | N/A | BILL M |  |  |  |  |  |  |  |  |  |  |
| 1212111050M |  | Klystron preliminary design complete (KLYSTRONS) | milestone | 0d | 2007-08-01 A | 2007-08-01 A | 1212111040, 1212111045 | 100% | 2007-09-04 | 2007-09-04 |  |  |  | 2007-05-18 |  | 0 | NELSON R | 1 | 1 | N/A | BILL M |  |  |  |  | 5 |  |  |  |  |  |
| 1212111070 |  | Develop Final Klystron Spec's (Klystrons) |  | 139d | 2007-10-01 A | 2008-04-25 A | 9-080M, 1212111055 | 100% |  |  | ELEC TECH [80 h]; ELEC DES [44 h]; TRAVEL | 7,200.31 | 5,074.6 |  | 0 | 7200.314 | NELSON R | 1 | 1 | N/A | BILL M |  |  |  |  |  |  |  |  |  |  |
| 1212111908LOE |  | FY08 Proj Admin (Klystrons) |  | 248d | 2007-10-01 A | 2008-09-30 A | 1212111007LOE, 9-080M | 100% |  |  | SR STAFF [1040 h] | 103,646.4 | 103,646.4 |  | 0 | 103646.4 | NELSON R | 1 | 1 | N/A | BILL M |  |  |  |  |  |  |  | 100 | 100 |  |
| 1212111075 |  | Write Final Rquirmnts/Prcrmnt Packages (Klystrons) |  | 108d | 2008-01-14 A | 2008-06-17 A | 1212111070 | 100% | 2008-01-14 | 2008-06-16 | SUPPLIES & MATERIALS; ELEC ENG [48 h] | 5,649.82 | 2,987.52 |  | 0 | 5649.822 | NELSON R | 1 | 1 | N/A | BILL M |  |  |  |  |  |  |  |  |  |  |
| 1212111080M |  | Comp klystron PED 2008 (KLYSTRONS) | milestone | 0d | 2008-06-17 A | 2008-06-17 A | 1212111075 | 100% | 2008-07-17 | 2008-07-17 |  |  |  |  |  | 0 | NELSON R | 1 | 1 | M | BILL M |  |  |  |  | 6 |  |  |  |  |  |
| 1212111170 |  | Pre-Constrctn Dsgn Review (Klystrons) |  | 4d | 2008-07-01 A | 2008-07-07 A | 1212111080M | 100% |  |  |  |  |  |  |  | 0 | NELSON R | 1 | 1 | Z | BILL M |  |  |  |  |  |  |  |  |  | C |
| 1212111085 |  | Release Prcrmnt Package for Klystron Solicitation (Klystrons) |  | 18d | 2008-08-06 A | 2008-08-29 A | 1212111075 FS+35d | 100% |  |  | SUPPLIES & MATERIALS; ELEC DES [40 h]; ELEC ENG [8 h] | 4,942.22 | 2,279.92 |  | 0 | 4942.222 | NELSON R | 1 | 1 | H | BILL M |  |  |  |  |  |  |  |  |  |  |
| 1212111100 |  | Eng-Receive & Evaluate Klystron Proposals (Klystrons) |  | 41d | 2008-10-01 A | 2008-11-26 A | 1212111085 | 100% |  |  | ELEC ENG [20 h] | 1,284.6 | 1,284.6 |  | 0 | 1244.8 | NELSON R | 1 | 1 | H | BILL M |  |  |  |  |  |  |  |  |  |  |
| 1212111110 |  | Des-Receive & Evaluate Klystron Proposals (Klystrons) |  | 47d | 2008-10-15 A | 2008-12-22 A | 1212111100 FS-10d | 100% |  |  | ELEC DES [40 h] | 1,839.2 | 1,839.2 |  | 0 | 1782 | NELSON R | 1 | 1 | H | BILL M |  |  |  |  |  |  |  |  |  |  |
| 1212111115 |  | Release Best & Final for Klystrons (Klystrons) |  | 7d | 2009-02-11 A | 2009-02-20 A | 1212111110 FS+30d | 100% |  |  | ELEC ENG [20 h] | 1,284.6 | 1,284.6 |  | 0 | 1244.8 | NELSON R | 1 | 1 | H | BILL M |  |  |  |  |  |  |  |  |  |  |
| 1212111120 |  | Final Klystron Evaluation (Klystrons)+ |  | 21d | 2009-02-23 A | 2009-03-23 A | 1212111115 | 100% |  |  | ELEC ENG [20 h] | 1,284.6 | 1,284.6 |  | 0 | 1244.8 | NELSON R | 1 | 1 | H | BILL M | 07-027 |  |  |  |  |  |  |  |  |  |
| 1212111175 |  | Re-Baseline Actuals Adjustment |  | 1d | 2013-08-30 A | 2013-08-30 A |  | 100% | 2013-09-03 | 2013-09-03 | PROCUREMENT>$50K 69 NO ESCALATION | -1,967.82 |  |  |  |  |  |  |  |  |  |  |  |  |  |  | 100 | ADJ |  |  |  |

| ID | WBS | Activity | Type | Duration | Start | Finish | Predecessors | Complete | Planned start | Planned finish | Resources | Cost | Actual cost | Planned FinishUDF | MONTHLY EV COST | RESP - Responsibility | STRT%COMP for CM EVM | FNSH%COMP for CM EVM | Milestone Level | EVMS Reporting Codes | CAM RESPONSIBLE | Calculated Remaining Total Cost | Remaining Material Cost Based on % Compl | Claimed Material Cost Based on % Complet | Initial Claimed Material Calc | Claimed Material Divider | LOE Divider | LOE Multiplier | CR 07-027 | CR 07-024 | WBS ASSIGNMENT | EXPNS ACT BRIDGING FY SPLIT | CR 09-001 | CR 08-016 | CR 09-012 | Duplications | ReBaseline Actuals Adjustment |
| --- | --- | --- | --- | --- | --- | --- | --- | --- | --- | --- | --- | --- | --- | --- | --- | --- | --- | --- | --- | --- | --- | --- | --- | --- | --- | --- | --- | --- | --- | --- | --- | --- | --- | --- | --- | --- | --- |
|  | 2 | **1.2.1.2.1.1.2 DC POWER** |  |  | 2006-10-02 | 2013-08-30 |  |  |  |  |  |  |  |  |  |  |  |  |  |  |  |  |  |  |  |  |  |  |  |  |  |  |  |  |  |  |  |
| 1212112000M |  | FY07 Begin DC Power PED efforts (DC POWER) | milestone | 0d | 2006-10-02 A | 2006-10-02 A | 9-070M | 100% |  |  |  |  |  | 2006-10-02 | 0 | NELSON R | 1 | 1 | 9 | N/A | BILL M |  |  |  |  |  |  |  |  |  |  |  |  |  |  |  |  |
| 1212112005 |  | Develop preliminary requirements for klystron HVPS (DC POWER) |  | 58d | 2006-10-02 A | 2006-12-22 A | 1212112000M | 100% |  |  | ELEC ENG [34.8 h] | 2,299.24 | 2,299.24 | 2006-10-20 | 2299.236 | NELSON R | 1 | 1 |  | N/A | BILL M | 0 |  |  |  |  |  |  |  |  |  |  |  |  |  |  |  |
| 1212112015 |  | Develop aux power supply requirements preliminary designs (includes rack configuration) (DC POWER) |  | 261d | 2006-11-01 A | 2007-11-19 A | 1212112010M | 100% |  |  | ELEC DES [34.8 h]; OFFICE [34.8 h]; ELEC ENG [208.8 h] | 15,623.26 | 15,623.26 | 2007-02-23 | 16257.864 | NELSON R | 1 | 1 |  | N/A | BILL M | 0 |  |  |  |  |  |  |  |  |  |  |  |  |  |  |  |
| 1212112010M |  | Preliminary HVPS requirements document complete (DC POWER) | milestone | 0d | 2006-12-22 A | 2006-12-22 A | 1212112005 | 100% | 2006-10-20 | 2006-10-20 |  |  |  | 2006-10-20 | 0 | NELSON R | 1 | 1 | 9 | N/A | BILL M |  |  |  |  |  |  |  |  |  |  |  |  |  |  |  |  |
| 1212112045 |  | Request budgetary pricing for HVPS (DC POWER) |  | 37d | 2007-03-02 A | 2007-04-23 A | 1212112035, 1212112040M | 100% |  |  | ELEC ENG [17.4 h] | 1,119.9 | 1,119.9 | 2007-04-20 | 1149.618 | NELSON R | 1 | 1 |  | N/A | BILL M | 0 |  |  |  |  |  |  |  |  |  |  |  |  |  |  |  |
| 1212112080 |  | Update costbook (DC POWER) |  | 22d | 2007-03-23 A | 2007-04-23 A | 1212112050M | 100% |  |  | ELEC ENG [34.8 h] | 2,199.27 | 2,199.27 | 2007-04-27 | 2299.236 | NELSON R | 1 | 1 |  | N/A | BILL M | 0 |  |  |  |  |  |  |  |  |  |  |  |  |  |  |  |
| 1212112020 |  | Develop preliminary layout/packaging designs (DC POWER) |  | 266.5d | 2007-03-30 A | 2008-04-25 A | 1212112010M, 1212112015 | 100% |  |  | ELEC DES [104.4 h]; SUPPLIES & MATERIALS; ELEC ENG [52.2 h] | 10,947.51 | 7,852.51 | 2007-07-17 | 11054.058132 | NELSON R | 1 | 1 |  | N/A | BILL M | 0 |  |  |  |  |  |  |  |  |  |  |  |  |  |  |  |
| 1212112025 |  | Conduct internal design & safety review (DC POWER) |  | 21d | 2007-04-16 A | 2007-05-14 A | 1212112010M FS+5d | 100% |  |  | ELEC ENG [34.8 h]; OFFICE [34.8 h] | 3,057.53 | 3,057.53 | 2007-03-09 | 3196.38 | NELSON R | 1 | 1 |  | N/A | BILL M | 0 |  |  |  |  |  |  |  |  |  |  |  |  |  |  |  |
| 1212112050M |  | Budgetary pricing received (DC POWER) | milestone | 0d | 2007-04-23 A | 2007-04-23 A | 1212112045 | 100% | 2007-01-03 | 2007-01-03 |  |  |  | 2007-04-20 | 0 | NELSON R | 1 | 1 | 9 | N/A | BILL M |  |  |  |  |  |  |  |  |  |  |  |  |  |  |  |  |
| 1212112085M |  | Costbook pricing updated (DC POWER) | milestone | 0d | 2007-04-23 A | 2007-04-23 A | 1212112080 | 100% | 2007-01-10 | 2007-01-10 |  |  |  | 2007-04-27 | 0 | NELSON R | 1 | 1 | 9 | N/A | BILL M |  |  |  |  |  |  |  |  |  |  |  |  |  |  |  |  |
| 1212112030M |  | Internal design & safety review complete (DC POWER) | milestone | 0d | 2007-05-14 A | 2007-05-14 A | 1212112010M, 1212112025 | 100% | 2006-11-10 | 2006-11-10 |  |  |  | 2007-03-09 | 0 | NELSON R | 1 | 1 | 5 | N/A | BILL M |  |  |  |  |  |  |  |  |  |  |  |  |  |  |  |  |
| 1212112035 |  | Revise requirements based on review outcome (DC POWER) |  | 27d | 2007-05-15 A | 2007-06-21 A | 1212112025, 1212112030M | 100% |  |  | ELEC ENG [52.2 h] | 3,242.66 | 3,242.66 | 2007-03-23 | 3448.854 | NELSON R | 1 | 1 |  | N/A | BILL M | 0 |  |  |  |  |  |  |  |  |  |  |  |  |  |  |  |
| 1212112055 |  | Procure components for preliminary design tests (DC POWER) |  | 122d | 2007-05-28 A | 2007-11-16 A | 1212112085M | 100% | 2007-05-29 | 2007-11-16 | ELEC ENG [17.4 h]; OFFICE [34.8 h]; PROCUREMENT<$50K 60 | 25,701.03 | 1,931.31 | 2007-05-11 | 25786.762 | NELSON R | 1 | 1 |  | N/A | BILL M | 0 | 0 | 23740 | 2374000 | 100 |  |  |  |  |  |  |  |  |  |  |  |
| 1212112040M |  | Requirements revised (DC POWER) | milestone | 0d | 2007-09-03 A | 2007-09-03 A | 1212112035 | 100% | 2007-10-01 | 2007-10-01 |  |  |  | 2007-03-23 | 0 | NELSON R | 1 | 1 | 9 | N/A | BILL M |  |  |  |  |  |  |  |  |  |  |  |  |  |  |  |  |
| 1212112908LOE |  | FY08 Office Supprt for Document Prep (DC POWER) |  | 248d | 2007-10-01 A | 2008-09-30 A | 1212111007LOE, 9-080M | 100% |  |  | OFFICE [240 h]; SUPPLIES & MATERIALS | 9,510.38 | 6,043.2 |  | 9510.384 | NELSON R | 1 | 1 |  | N/A | BILL M | 0 |  |  |  |  | 100 | 100 |  |  |  |  |  |  |  |  |  |
| 1212112090M |  | FY08 Begin DC Pwr PED (DC POWER) | milestone | 0d | 2007-10-03 A | 2007-10-03 A | 9-080M, 1212112075M | 100% | 2008-01-03 | 2008-01-03 |  |  |  |  | 0 | NELSON R | 1 | 1 | 6 | N/A | BILL M |  |  |  |  |  |  |  | 07-027 |  |  |  |  |  |  |  |  |
| 1212112065 |  | Build & test preliminary designs (fil/mod anode) (DC POWER) |  | 160d | 2007-10-04 A | 2008-05-30 A | 1212112060M FS-20d | 100% |  |  | SUPPLIES & MATERIALS; ELEC ENG [229.68 h]; ELEC TECH [417.6 h] | 33,647.45 | 30,552.45 | 2007-08-21 | 35566.9496 | NELSON R | 1 | 1 |  | N/A | BILL M | 0 |  |  |  |  |  |  |  |  |  |  |  |  |  |  |  |
| 1212112060M |  | Components received for preliminary design tests (DC POWER) | milestone | 0d | 2007-11-16 A | 2007-11-16 A | 1212112055 | 100% | 2008-01-16 | 2008-01-16 |  |  |  | 2007-05-11 | 0 | NELSON R | 1 | 1 | 9 | N/A | BILL M |  |  |  |  |  |  |  |  |  |  |  |  |  |  |  |  |
| 1212112070 |  | Revise preliminary designs (DC POWER) |  | 49d | 2008-04-11 A | 2008-06-20 A | 1212112065, 1212112040M, 1212112060M | 100% | 2008-04-11 | 2008-06-19 | ELEC ENG [69.6 h]; ELEC DES [34.8 h] | 5,882.24 | 5,882.24 | 2007-09-28 | 6163.776 | NELSON R | 1 | 1 |  | N/A | BILL M | 0 |  |  |  |  |  |  |  |  |  |  |  |  |  |  |  |
| 1212112075M |  | Preliminary designs revised (DC POWER) | milestone | 0d | 2008-06-20 A | 2008-06-20 A | 1212112070 | 100% | 2008-07-29 | 2008-07-29 |  |  |  | 2007-09-28 | 0 | NELSON R | 1 | 1 | 5 | M | BILL M |  |  |  |  |  |  |  |  |  |  |  |  |  |  |  |  |
| 1212112100 |  | Dsgn & Test filament Pwr Supply (DC POWER) |  | 109d | 2008-06-23 A | 2008-11-24 A | 1212112090M FS+120d | 100% |  |  | PROCUREMENT<$50K 60; ELEC ENG [360 h]; ELEC TECH [560 h]; ELEC DES [120 h] | 59,406.49 | 50,119.39 |  | 58840.3 | NELSON R | 1 | 1 |  | N/A | BILL M | 0 | 0 | 9287.1 | 928710 | 100 |  |  |  | 07-024 |  |  |  |  |  |  |  |
| 1212112110 |  | Dsgn & Test Mods anode Pwr Supply (DC POWER) |  | 163d | 2008-06-23 A | 2009-02-20 A | 1212112105 FS-40d | 100% |  |  | PROCUREMENT<$50K 60; ELEC ENG [480 h]; ELEC DES [120 h]; ELEC TECH [480 h] | 64,177.19 | 54,890.09 |  | 63194.7 | NELSON R | 1 | 1 |  | N/A | BILL M | 0 | 0 | 9287.1 | 928710 | 100 |  |  |  |  |  |  |  |  |  |  |  |
| 1212112105 |  | Prep Documentation for Fab:/Prcrmnt filament (DC POWER) |  | 186d | 2008-07-24 A | 2009-04-24 A | 1212112100 | 100% |  |  | ELEC DES [80 h] | 3,648.88 | 3,648.88 |  | 3564 | NELSON R | 1 | 1 |  | H | BILL M | 0 |  |  |  |  |  |  |  |  |  |  |  |  |  |  |  |
| 1212112115 |  | FY08 Prep Documentation for Fab/Prcrmnt: Mods anode (DC POWER) |  | 40d | 2008-08-15 A | 2008-10-13 A | 1212112110 | 100% | 2008-08-15 | 2008-10-10 | ELEC DES [112 h] | 5,021.63 | 5,021.63 |  | 4989.6 | NELSON R | 1 | 1 |  | N/A | BILL M | 0 |  |  |  |  |  |  |  |  | 1.2.1.2.1.1.2 | EXP0809 | 09-001 |  |  |  |  |
| 1212112120 |  | PROC Dsgn & Test Ion Pump Pwr Supply (DC POWER) |  | 170d | 2008-08-15 A | 2009-04-24 A | 1212112115a FS-15d | 100% |  |  | PROCUREMENT<$50K 60 NO ESCALATION FY09 | 6,191.4 |  |  | 6191.4 | NELSON R | 1 | 1 |  | N/A | BILL M | 0 | 0 | 6191.4 | 619140 | 100 |  |  |  |  | 1.2.1.2.1.1.2 | EXP0809 | 09-001 | 08-016 | 09-012 |  |  |
| 1212112120b |  | FY09 LAB/EXP Dsgn & Test Ion Pump Pwr Supply (DC POWER) |  | 175d | 2008-09-08 A | 2009-05-22 A | 1212112120a | 100% |  |  | ELEC ENG [400 h]; ELEC DES [100 h]; ELEC TECH [400 h] | 46,218.6 | 46,218.6 |  | 46358 | NELSON R | 1 | 1 |  | N/A | BILL M | 0 |  |  |  |  |  |  |  |  | 1.2.1.2.1.1.2 | EXP0809 | 09-001 | 08-016 |  |  |  |
| 1212112120a |  | FY08 LAB/EXP Dsgn & Test Ion Pump Pwr Supply (DC POWER) |  | 13d | 2008-09-12 A | 2008-09-30 A | 1212112115a FS-15d | 100% |  |  | ELEC DES [20 h]; ELEC TECH [80 h]; ELEC ENG [80 h] | 8,984.6 | 8,984.6 |  | 8984.6 | NELSON R | 1 | 1 |  | N/A | BILL M | 0 |  |  |  |  |  |  |  |  | 1.2.1.2.1.1.2 | EXP0809 | 09-001 | 08-016 |  |  |  |
| 1212112115a |  | FY09 Prep Documentation for Fab/Prcrmnt: Mods anode (DC POWER) |  | 71d | 2008-10-31 A | 2009-02-20 A | 1212112115 | 100% |  |  | ELEC DES [8 h] | 367.84 | 367.84 |  | 367.84 | NELSON R | 1 | 1 |  | N/A | BILL M | 0 |  |  |  |  |  |  |  |  | 1.2.1.2.1.1.2 | EXP0809 | 09-001 |  |  |  |  |
| 1212112130a |  | FY08 LAB/EXP Dsgn HPA/Rack Sys & Inj. Upgrade(DC POWER) |  | 78d | 2008-11-20 A | 2009-03-23 A | 1212112100 | 100% |  |  | ELEC DES [93.79 h]; ELEC ENG [281.38 h]; ELEC TECH [150.07 h]; SUPPLIES & MATERIALS; MECH DES [225.1 h] | 40,280.8 | 38,282.19 |  | 39094.5188 | NELSON R | 1 | 1 |  | N/A | BILL M | 0 |  |  |  |  |  |  |  | 07-024 | 1.2.1.2.1.1.2 | EXP0809 | 09-001 | 08-016 |  | DUP |  |
| 1212112130 |  | PROC Dsgn HPA/Rack Sys & Inj. Upgrade(DC POWER) |  | 158d | 2009-01-16 A | 2009-08-31 A | 1212112100 | 100% |  |  | PROCUREMENT<$50K 60 NO ESCALATION FY09 | 12,382.8 |  |  | 12382.8 | NELSON R | 1 | 1 |  | N/A | BILL M | 0 | 0 | 12382.8 | 1238280 | 100 |  |  |  | 07-024 | 1.2.1.2.1.1.2 | EXP0809 | 09-001 | 08-016 | 09-012 | DUP |  |
| 1212112140 |  | Prep Final Rquirmnts Package for HV PS Prcrmnt (DC POWER) |  | 69d | 2009-01-16 A | 2009-04-24 A | 1212112135, 1212112125 | 100% |  |  | TRAVEL; ELEC ENG [120 h]; ELEC DES [40 h] | 12,847.73 | 9,546.8 |  | 12847.734591 | NELSON R | 1 | 1 |  | H | BILL M | 0 |  |  |  |  |  |  |  |  |  |  |  |  |  |  |  |
| 1212112130b |  | FY09 LAB/EXP Dsgn HPA/Rack Sys & Inj. Upgrade(DC POWER) |  | 134d | 2009-03-23 A | 2009-09-29 A | 1212112130a | 100% |  |  | SUPPLIES & MATERIALS; MECH DES [254.9 h]; ELEC DES [106.21 h]; ELEC ENG [318.62 h]; ELEC TECH [169.93 h] | 45,684.73 | 43,349.41 |  | 45684.7225 | NELSON R | 1 | 1 |  | N/A | BILL M | 0 |  |  |  |  |  |  |  | 07-024 | 1.2.1.2.1.1.2 | EXP0809 | 09-001 | 08-016 |  | DUP |  |
| 1212112125 |  | Prep Documentation for Fab/Prcrmnt; ION (DC POWER) |  | 60d | 2009-04-30 A | 2009-07-24 A | 1212112120, 1212112120b | 100% |  |  | ELEC DES [80 h] | 3,678.4 | 3,678.4 |  | 3678.4 | NELSON R | 1 | 1 |  | H | BILL M | 0 |  |  |  |  |  |  |  |  |  |  |  |  |  |  |  |
| 1212112135 |  | Prep Documentation for Fab/Prcrmnt (DC POWER) |  | 109d | 2009-05-29 A | 2009-10-30 A | 1212112130 FS-125d, 1212112130b FS-100d | 100% |  |  | ELEC ENG [160 h]; ELEC DES [160 h] | 17,746.63 | 17,746.63 |  | 17633.6 | NELSON R | 1 | 1 |  | H | BILL M | 0 |  |  |  |  |  |  |  |  |  |  |  |  | 09-012 |  |  |
| 1212112145M |  | Finish 2008 DC Pwr PED (DC POWER)+ | milestone | 0d | 2009-10-30 A | 2009-10-30 A | 1212112140 | 100% | 2009-11-24 | 2009-11-24 |  |  |  |  | 0 | NELSON R | 1 | 1 | 6 | M | BILL M |  |  |  |  |  |  |  | 07-027 |  |  |  |  |  |  |  |  |
| 1212112150 |  | Re-Baseline Actuals Adjustment |  | 1d | 2013-08-30 A | 2013-08-30 A |  | 100% | 2013-09-03 | 2013-09-03 | PROCUREMENT>$50K 69 NO ESCALATION | -61,159.81 |  |  |  |  |  |  |  |  |  |  |  |  |  | 100 |  |  |  |  |  |  |  |  |  |  | ADJ |

Notes:
- 1212112090M: Entry Criteria: Ext Pred: / 1212112075M
- 1212112100: Entry Criteria: Ext Pred: klystron sufficiently / defined to define needs
- 1212112140: Entry Criteria: Ext Pred: klystron sufficiently / defined to define needs
- 1212112135: Explanation: 28 May 2009 added neg lag to / close up the "gap" Increased the duration.

| ID | WBS | Activity | Type | Duration | Start | Finish | Predecessors | Complete | Planned start | Planned finish | Resources | Cost | Actual cost | Planned FinishUDF | MONTHLY EV COST | RESP - Responsibility | STRT%COMP for CM EVM | FNSH%COMP for CM EVM | Milestone Level | EVMS Reporting Codes | CAM RESPONSIBLE | Calculated Remaining Total Cost | CR 07-027 | CR 09-012 | WBS ASSIGNMENT | EXPNS ACT BRIDGING FY SPLIT | CR 09-001 | Claimed Material Divider | ReBaseline Actuals Adjustment | Remaining Material Cost Based on % Compl | Claimed Material Cost Based on % Complet | Initial Claimed Material Calc | CR 08-009 | CR 08-016 |
| --- | --- | --- | --- | --- | --- | --- | --- | --- | --- | --- | --- | --- | --- | --- | --- | --- | --- | --- | --- | --- | --- | --- | --- | --- | --- | --- | --- | --- | --- | --- | --- | --- | --- | --- |
|  | 3 | **1.2.1.2.1.1.3 WAVEGUIDE COMPONENTS** |  |  | 2006-10-02 | 2013-08-30 |  |  |  |  |  |  |  |  |  |  |  |  |  |  |  |  |  |  |  |  |  |  |  |  |  |  |  |  |
| 1212113000M |  | Begin waveguide PED effort (WVGUIDE COMPON) | milestone | 0d | 2006-10-02 A | 2006-10-02 A | 9-070M | 100% |  |  |  |  |  | 2006-10-02 | 0 | NELSON R | 1 | 1 | 9 | N/A | BILL M |  |  |  |  |  |  |  |  |  |  |  |  |  |
| 1212113005 |  | Develop preliminary waveguide requirements and layout (WVGUIDE COMPON) |  | 232d | 2006-12-14 A | 2007-11-19 A | 1212113000M | 100% |  |  | ELEC TECH [69.6 h]; ELEC ENG [52.2 h]; ELEC DES [69.6 h] | 9,115.75 | 9,115.75 | 2007-03-30 | 9462.294 | NELSON R | 1 | 1 |  | N/A | BILL M | 0 |  |  |  |  |  |  |  |  |  |  |  |  |
| 1212113030 |  | Request budgetary pricing for waveguide components (WVGUIDE COMPON) |  | 36d | 2007-03-05 A | 2007-04-23 A | 1212113025M | 100% |  |  | ELEC ENG [17.4 h] | 1,119.07 | 1,119.07 | 2007-05-18 | 1080.888 | NELSON R | 1 | 1 |  | N/A | BILL M | 0 |  |  |  |  |  |  |  |  |  |  |  |  |
| 1212113040 |  | Revise costbook pricing (WVGUIDE COMPON) |  | 22d | 2007-03-23 A | 2007-04-23 A | 1212113035M | 100% |  |  | ELEC ENG [17.4 h] | 1,099.63 | 1,099.63 | 2007-05-25 | 1080.888 | NELSON R | 1 | 1 |  | N/A | BILL M | 0 |  |  |  |  |  |  |  |  |  |  |  |  |
| 1212113045M |  | Costbook revised (WVGUIDE COMPON) | milestone | 0d | 2007-04-23 A | 2007-04-23 A | 1212113040 | 100% | 2007-05-25 | 2007-05-25 |  |  |  | 2007-05-25 | 0 | NELSON R | 1 | 1 | 9 | N/A | BILL M |  |  |  |  |  |  |  |  |  |  |  |  |  |
| 1212113010 |  | Conduct internal design & safety review (WVGUIDE COMPON) |  | 5d | 2007-05-14 A | 2007-05-18 A | 1212113000M, 1212113005 | 100% |  |  | ELEC ENG [17.4 h]; OFFICE [34.8 h] | 1,976.64 | 1,976.64 | 2007-04-13 | 1976.64 | NELSON R | 1 | 1 |  | N/A | BILL M | 0 |  |  |  |  |  |  |  |  |  |  |  |  |
| 1212113020 |  | Revise preliminary designs (WVGUIDE COMPON) |  | 127d | 2007-05-18 A | 2007-11-15 A | 1212113015M | 100% |  |  | ELEC ENG [17.4 h] | 1,065.87 | 1,065.87 | 2007-04-20 | 1080.888 | NELSON R | 1 | 1 |  | N/A | BILL M | 0 |  |  |  |  |  |  |  |  |  |  |  |  |
| 1212113015M |  | Design & safety review complete (WVGUIDE COMPON) | milestone | 0d | 2007-05-18 A | 2007-05-18 A | 1212113005, 1212113000M, 1212113010 | 100% | 2007-04-13 | 2007-04-13 |  |  |  | 2007-04-13 | 0 | NELSON R | 1 | 1 | 4 | N/A | BILL M |  |  |  |  |  |  |  |  |  |  |  |  |  |
| 1212113035M |  | Receive budgetary pricing (WVGUIDE COMPON) | milestone | 0d | 2007-06-23 A | 2007-06-23 A | 1212113030 | 100% | 2007-05-18 | 2007-05-18 |  |  |  | 2007-05-18 | 0 | NELSON R | 1 | 1 | 9 | N/A | BILL M |  |  |  |  |  |  |  |  |  |  |  |  |  |
| 1212113025M |  | Requirements revised (WVGUIDE COMPON) | milestone | 0d | 2007-11-15 A | 2007-11-15 A | 1212113020 | 100% | 2008-01-15 | 2008-01-15 |  |  |  | 2007-04-20 | 0 | NELSON R | 1 | 1 | 9 | N/A | BILL M |  |  |  |  |  |  |  |  |  |  |  |  |  |
| 1212113050M |  | Begin final design (WVGUIDE COMPON) | milestone | 0d | 2007-11-16 A | 2007-11-16 A | 1212113045M | 100% | 2008-01-16 | 2008-01-16 |  |  |  | 2007-05-28 | 0 | NELSON R | 1 | 1 | 9 | N/A | BILL M |  |  |  |  |  |  |  |  |  |  |  |  |  |
| 1212113055 |  | Final design Phase (WVGUIDE COMPON) |  | 237d | 2007-11-16 A | 2008-10-31 A | 1212113050M | 100% |  |  | ELEC TECH [69.6 h] | 2,717.9 | 2,717.9 | 2007-09-28 | 2668.901654 | NELSON R | 1 | 1 |  | N/A | BILL M | 0 | 07-027 |  |  |  |  |  |  |  |  |  |  |  |
| 1212113060M |  | Begin 2008 Waveguide Systems PED (WVGUIDE COMPON) | milestone | 0d | 2008-01-25 A | 2008-01-25 A | 9-080M FS+180d, 1212113055 | 100% | 2008-06-25 | 2008-06-25 |  |  |  |  | 0 | NELSON R | 1 | 1 | 6 | N/A | BILL M |  | 07-027 |  |  |  |  |  |  |  |  |  |  |  |
| 1212113075 |  | Develop Rquirmnts Package for HOM Filter (WVGUIDE COMPON) |  | 0d | 2008-01-25 A | 2008-01-25 A | 1212113070 FS-20d | 100% |  |  |  |  |  |  | 0 | NELSON R | 1 | 1 |  | N/A | BILL M |  | 07-027 | 09-012 |  |  |  |  |  |  |  |  |  |  |
| 1212113070 |  | Develop Rquirmnts Package for circulator (WVGUIDE COMPON) |  | 259d | 2008-02-11 A | 2009-02-25 A | 1212113060M | 100% |  |  | ELEC DES [20 h]; SUPPLIES & MATERIALS; ELEC TECH [40 h]; ELEC ENG [80 h] | 10,982.57 | 7,515.39 |  | 10894.584 | NELSON R | 1 | 1 |  | N/A | BILL M | 0 |  |  |  |  |  |  |  |  |  |  |  |  |
| 1212113080 |  | FY08 Develop Rquirmnts Packages for Custom Waveguide pcs (WVGUIDE COMPON) |  | 162.48d | 2008-02-11 A | 2008-09-30 A | 1212113075 | 100% |  |  | MECH DES [105.6 h]; SUPPLIES & MATERIALS; ELEC ENG [105.6 h]; ELEC DES [52.8 h]; ELEC TECH [52.8 h] | 18,278.92 | 15,466.17 |  | 18278.926 | NELSON R | 1 | 1 |  | N/A | BILL M | 0 |  |  | 1.2.1.2.1.1.3 | EXP0809 | 09-001 |  |  |  |  |  |  |  |
| 1212113065 |  | Office Admin Supprt (WVGUIDE COMPON) |  | 21d | 2008-09-01 A | 2008-09-30 A | 1212113060M | 100% | 2008-09-02 | 2008-09-30 | OFFICE [80 h] | 2,014.4 | 2,014.4 |  | 2014.4 | NELSON R | 1 | 1 |  | H | BILL M | 0 |  |  |  |  |  |  |  |  |  |  |  |  |
| 1212113080a |  | FY09 Develop Rquirmnts Packages for Custom Waveguide pcs (WVGUIDE COMPON) |  | 103d | 2008-09-22 A | 2009-02-25 A | 1212113080 | 100% |  |  | SUPPLIES & MATERIALS; ELEC DES [27.2 h]; ELEC ENG [54.4 h]; ELEC TECH [27.2 h]; MECH DES [54.4 h] | 9,700.17 | 8,204.96 |  | 9717.498 | NELSON R | 1 | 1 |  | N/A | BILL M | 0 |  |  | 1.2.1.2.1.1.3 | EXP0809 | 09-001 |  |  |  |  |  |  |  |
| 1212113085 |  | Revise Vend Pricing for Waveguide Compnts (WVGUIDE COMPON) |  | 17d | 2008-11-26 A | 2008-12-22 A | 1212113080a | 100% |  |  | ELEC ENG [40 h] | 2,569.2 | 2,569.2 |  | 2569.2 | NELSON R | 1 | 1 |  | H | BILL M | 0 |  |  |  |  |  |  |  |  |  |  |  |  |
| 1212113090M |  | Waveguide PED Comp 2008 (WVGUIDE COMPON)++ | milestone | 0d | 2009-02-25 A | 2009-02-25 A | 1212113085, 1212113065 | 100% | 2009-03-26 | 2009-03-26 |  |  |  |  | 0 | NELSON R | 1 | 1 | 6 | M | BILL M |  |  |  |  |  |  |  |  |  |  |  |  |  |
| 1212113170 |  | Pre-Constrctn Dsgn Review (WVGUIDE COMPON)+ |  | 3d | 2009-07-01 A | 2009-07-06 A | 1212113090M | 100% |  |  |  |  |  |  | 0 | NELSON R | 1 | 1 |  | Z | BILL M |  | 07-027 |  |  |  |  |  |  |  |  |  |  |  |
| 1212113175 |  | Re-Baseline Actuals Adjustment |  | 1d | 2013-08-30 A | 2013-08-30 A |  | 100% | 2013-09-03 | 2013-09-03 | PROCUREMENT>$50K 69 NO ESCALATION | -20,415.45 |  |  |  |  |  |  |  |  |  |  |  |  |  |  |  | 100 | ADJ |  |  |  |  |  |
|  | 2 | **1.2.1.2.1.2 CONTROL** |  |  | 2006-10-02 | 2013-08-30 |  |  |  |  |  |  |  |  |  |  |  |  |  |  |  |  |  |  |  |  |  |  |  |  |  |  |  |  |
|  | 1 | **1.2.1.2.1.2.1 FIELD CONTROL (RF/DSP)** |  |  | 2006-10-02 | 2013-08-30 |  |  |  |  |  |  |  |  |  |  |  |  |  |  |  |  |  |  |  |  |  |  |  |  |  |  |  |  |
| 1212121000M |  | Preliminary Integrated LLRF System Design (FLD CNTL) | milestone | 0d | 2006-10-02 A | 2006-10-02 A | 9-070M FS+44d | 100% | 2006-12-05 | 2006-12-05 |  |  |  | 2006-12-05 | 0 | HOVATER C | 1 | 1 | 9 | N/A | BILL M |  |  |  |  |  |  |  |  |  |  |  |  |  |
| 1212121030M |  | Begin Preliminary Digital Board Design (FLD CNTL) | milestone | 0d | 2006-10-02 A | 2006-10-02 A | 9-070M | 100% |  |  |  |  |  | 2006-10-02 | 0 | HOVATER C | 1 | 1 | 9 | N/A | BILL M |  |  |  |  |  |  |  |  |  |  |  |  |  |
| 1212121035 |  | Develop Detailed Specification (FLD CNTL) |  | 79d | 2006-10-02 A | 2007-01-31 A | 1212121030M | 100% |  |  | ELEC ENG [34.8 h] | 2,299.24 | 2,299.24 | 2006-10-27 | 2299.236 | HOVATER C | 1 | 1 |  | N/A | BILL M | 0 |  |  |  |  |  |  |  |  |  |  |  |  |
| 1212121065 |  | Develop RF Board Detailed specification (FLD CNTL) |  | 98d | 2006-10-02 A | 2007-02-28 A | 1212121060M | 100% |  |  | ELEC ENG [34.8 h] | 2,299.24 | 2,299.24 | 2006-10-27 | 2299.236 | HOVATER C | 1 | 1 |  | N/A | BILL M | 0 |  |  |  |  |  |  |  |  |  |  |  |  |
| 1212121040 |  | Develop Preliminary Design Digital Board (FLD CNTL) |  | 221d | 2006-11-01 A | 2007-09-24 A | 1212121035 | 100% |  |  | ELEC DES [243.6 h]; ELEC TECH [69.6 h]; ELEC ENG [278.4 h] | 31,258.09 | 31,258.09 | 2007-02-01 | 32233.848 | HOVATER C | 1 | 1 |  | N/A | BILL M | 0 |  |  |  |  |  |  |  |  |  |  |  |  |
| 1212121070 |  | Preliminary RF Board Design Complete (FLD CNTL) |  | 111d | 2006-11-01 A | 2007-04-18 A | 1212121065 | 100% |  |  | ELEC ENG [174 h]; ELEC DES [243.6 h]; ELEC TECH [69.6 h] | 25,237.96 | 25,237.96 | 2007-01-03 | 25336.14 | HOVATER C | 1 | 1 |  | N/A | BILL M | 0 |  |  |  |  |  |  |  |  |  |  |  |  |
| 1212121005 |  | Develop Preliminary System Design (FLD CNTL) |  | 99d | 2006-12-01 A | 2007-04-30 A | 1212121000M | 100% |  |  | SCIENTIST [69.6 h]; COMP SCIENT [34.8 h]; ELEC ENG [208.8 h] | 20,095.52 | 20,095.52 | 2007-04-05 | 20235.4866 | HOVATER C | 1 | 1 |  | N/A | BILL M | 0 |  |  |  |  |  |  |  |  |  |  |  |  |
| 1212121010 |  | Investigate Comparitive System Designs (FLD CNTL) |  | 99d | 2006-12-01 A | 2007-04-30 A | 1212121000M FS+20d | 100% |  |  | SCIENTIST [34.8 h]; ELEC ENG [104.4 h]; TRAVEL | 24,519.24 | 9,039.24 | 2007-04-05 | 24582.52 | HOVATER C | 1 | 1 |  | N/A | BILL M | 0 |  |  |  |  |  |  |  |  |  |  |  |  |
| 1212121045 |  | Procure Digital Board validation unit (FLD CNTL) |  | 210d | 2006-12-01 A | 2007-10-05 A | 1212121040 | 100% |  |  | PROCUREMENT<$50K 60 | 6,190 |  | 2007-02-07 | 6190 | HOVATER C | 1 | 1 |  | N/A | BILL M | 0 |  |  |  |  |  | 100 |  | 0 | 6190 | 619000 |  |  |
| 1212121015 |  | Update LLRF Model (FLD CNTL) |  | 97d | 2007-01-02 A | 2007-05-18 A | 1212121000M | 100% |  |  | ELEC ENG [17.4 h]; SCIENTIST [156.6 h] | 11,140.25 | 11,140.25 | 2007-05-01 | 11201.772 | HOVATER C | 1 | 1 |  | N/A | BILL M | 0 |  |  |  |  |  |  |  |  |  |  |  |  |
| 1212121050 |  | Conduct Digital Board Validation Tests (FLD CNTL) |  | 260d | 2007-01-02 A | 2008-01-21 A | 1212121045 | 100% | 2007-01-02 | 2008-01-18 | ELEC DES [34.8 h]; COMP SCIENT [34.8 h]; ELEC TECH [69.6 h]; ELEC ENG [174 h] | 17,185.69 | 17,185.69 | 2007-04-05 | 17876.76 | HOVATER C | 1 | 1 |  | N/A | BILL M | 0 |  |  |  |  |  |  |  |  |  |  |  |  |
| 1212121075 |  | Procure RF Board validation unit (FLD CNTL) |  | 109d | 2007-02-27 A | 2007-07-31 A | 1212121070 | 100% |  |  | PROCUREMENT<$50K 60 | 6,190 |  | 2007-01-09 | 6190 | HOVATER C | 1 | 1 |  | N/A | BILL M | 0 |  |  |  |  |  | 100 |  | 0 | 6190 | 619000 |  |  |
| 1212121020 |  | Develop Preliminary Design (FLD CNTL) |  | 18.5d | 2007-03-02 A | 2007-03-28 A | 1212121115, 1212121015 | 100% |  |  | ELEC ENG [17.4 h] | 1,149.62 | 1,149.62 | 2007-05-03 | 1080.888 | HOVATER C | 1 | 1 |  | N/A | BILL M | 0 |  |  |  |  |  |  |  |  |  |  |  |  |
| 1212121115 |  | Update PED Cost and Schedule (FLD CNTL) |  | 32d | 2007-03-02 A | 2007-04-16 A | 1212121110M | 100% |  |  | ELEC ENG [34.8 h] | 2,251.98 | 2,251.98 | 2007-04-12 | 2271.744 | HOVATER C | 1 | 1 |  | N/A | BILL M | 0 |  |  |  |  |  |  |  |  |  |  |  |  |
| 1212121120 |  | Update Construction Cost and Schedule (FLD CNTL) |  | 37d | 2007-03-02 A | 2007-04-23 A | 1212121110M | 100% |  |  | ELEC TECH [17.2 h]; ELEC ENG [34.8 h] | 2,936.07 | 2,936.07 | 2007-03-22 | 3011.66 | HOVATER C | 1 | 1 |  | N/A | BILL M | 0 |  |  |  |  |  |  |  |  |  |  |  |  |
| 1212121125 |  | Prepare for EIR (FLD CNTL) |  | 61d | 2007-03-02 A | 2007-05-25 A | 1212121110M | 100% |  |  | ELEC ENG [34.8 h]; ELEC TECH [34.8 h] | 3,601 | 3,601 | 2007-05-01 | 3740.652 | HOVATER C | 1 | 1 |  | N/A | BILL M | 0 |  |  |  |  |  |  |  |  |  |  |  |  |
| 1212121020M |  | Preliminary Design Complete (FLD CNTL) | milestone | 0d | 2007-03-28 A | 2007-03-28 A | 1212121020 | 100% | 2007-04-17 | 2007-04-17 |  |  |  | 2007-05-03 | 0 | HOVATER C | 1 | 1 | 5 | N/A | BILL M |  |  |  |  |  |  |  |  |  |  |  |  |  |
| 1212121110M |  | Start Cost & Schedule Update (FLD CNTL) | milestone | 0d | 2007-04-23 A | 2007-04-23 A | 1212121075, 1212121045 | 100% | 2007-02-08 | 2007-02-08 |  |  |  | 2007-02-08 | 0 | HOVATER C | 1 | 1 | 9 | N/A | BILL M |  |  |  |  |  |  |  |  |  |  |  |  |  |
| 1212121025 |  | Conduct Preliminary Design & Safety Review 1.2.1.2.1.2 LLRF (FLD CNTL) |  | 28d | 2007-04-30 A | 2007-06-08 A | 1212121120, 1212121020M, 1212121020 | 100% |  |  | ELEC ENG [139.2 h]; SCIENTIST [34.8 h]; COMP SCIENT [34.8 h]; OFFICE [34.8 h]; TRAVEL | 18,936.27 | 13,776.27 | 2007-06-01 | 18936.276 | HOVATER C | 1 | 1 |  | N/A | BILL M | 0 |  |  |  |  |  |  |  |  |  |  |  |  |
| 1212121130M |  | Field Control Ready for Baseline (FLD CNTL) | milestone | 0d | 2007-05-25 A | 2007-05-25 A | 1212121125 | 100% | 2006-12-22 | 2006-12-22 |  |  |  | 2007-05-01 | 0 | HOVATER C | 1 | 1 | 5 | N/A | BILL M |  |  |  |  |  |  |  |  |  |  |  |  |  |
| 1212121060M |  | Start Preliminary RF Board design (FLD CNTL) | milestone | 0d | 2007-07-02 A | 2007-07-02 A | 9-070M | 100% | 2006-10-02 | 2006-10-02 |  |  |  | 2006-10-02 | 0 | HOVATER C | 1 | 1 | 9 | N/A | BILL M |  |  |  |  |  |  |  |  |  |  |  |  |  |
| 1212121080 |  | Conduct RF Board Validation tests (FLD CNTL) |  | 120d | 2007-07-02 A | 2007-12-20 A | 1212121075 FS+40d | 100% |  |  | ELEC DES [34.8 h]; ELEC ENG [174 h]; ELEC TECH [70 h] | 14,860.12 | 14,860.12 | 2007-03-08 | 15457.364 | HOVATER C | 1 | 1 |  | N/A | BILL M | 0 |  |  |  |  |  |  |  |  |  |  |  |  |
| 1212121085M |  | RF Board Validation Tests complete (FLD CNTL) | milestone | 0d | 2007-12-20 A | 2007-12-20 A | 1212121080 | 100% | 2008-02-28 | 2008-02-28 |  |  |  | 2007-03-08 | 0 | HOVATER C | 1 | 1 | 5 | N/A | BILL M |  |  |  |  |  |  |  |  |  |  |  |  |  |
| 1212121090M |  | Start Field Control System Test (FLD CNTL) | milestone | 0d | 2008-01-14 A | 2008-01-14 A | 1212121005, 1212121010, 1212121055M FS+80d | 100% | 2008-05-14 | 2008-05-14 |  |  |  | 2007-04-06 | 0 | HOVATER C | 1 | 1 | 9 | N/A | BILL M |  | 07-027 |  |  |  |  |  |  |  |  |  |  |  |
| 1212121095 |  | Modify Field Control Firmware (FLD CNTL) |  | 42d | 2008-01-14 A | 2008-03-13 A | 1212121090M | 100% |  |  | ELEC ENG [139.2 h]; PROCUREMENT<$50K 60; COMP SCIENT [34.8 h] | 15,837.69 | 10,677.69 | 2007-06-29 | 15507.43896 | HOVATER C | 1 | 1 |  | N/A | BILL M | 0 |  |  |  |  |  | 100 |  | 0 | 5160 | 516000 |  |  |
| 1212121100 |  | Conduct Field Control System Validation (FLD CNTL) |  | 65d | 2008-01-14 A | 2008-04-15 A | 1212121050, 1212121085M | 100% |  |  | PROCUREMENT<$50K 60; ELEC ENG [139.2 h] | 13,823.81 | 8,663.81 | 2007-08-08 | 13656.417216 | HOVATER C | 1 | 1 |  | N/A | BILL M | 0 |  |  |  |  |  | 100 |  | 0 | 5160 | 516000 |  |  |
| 1212121140 |  | Assess Hardware Dsgn (FLD CONT) |  | 247d | 2008-01-19 A | 2009-01-19 A | 1212121135B, 1212121135Bb FS-40d | 100% | 2008-01-22 | 2009-01-16 | ELEC ENG [828 h]; ELEC DES [640 h]; PROCUREMENT<$50K 60; ELEC TECH [172 h] | 109,507.3 | 87,529.46 |  | 111496.71547 | HOVATER C | 1 | 1 |  | N/A | BILL M | 0 | 07-027 |  |  |  |  | 100 |  | 0 | 21977.84 | 2197784 | 08-009 |  |
| 1212121055M |  | Digital Board Validation Tests complete (FLD CNTL) | milestone | 0d | 2008-01-21 A | 2008-01-21 A | 1212121050 FS+8d | 100% | 2008-03-04 | 2008-03-04 |  |  |  | 2007-04-05 | 0 | HOVATER C | 1 | 1 | 5 | N/A | BILL M |  |  |  |  |  |  |  |  |  |  |  |  |  |
| 1212121105M |  | Field Control System validation complete (FLD CNTL) | milestone | 0d | 2008-04-15 A | 2008-04-15 A | 1212121100, 1212121025 | 100% | 2008-05-15 | 2008-05-15 |  |  |  | 2007-08-08 | 0 | HOVATER C | 1 | 1 | 5 | M | BILL M |  |  |  |  |  |  |  |  |  |  |  |  |  |
| 1212121135 |  | Validation Testing on Cavity Phase 1 (FLD CONT) |  | 43d | 2008-05-01 A | 2008-07-01 A | 1212121105M, 9-080M | 100% |  |  | SCIENTIST [20.36 h]; ELEC TECH [50.89 h]; COMP SCIENT [81.42 h]; ELEC ENG [81.42 h] | 13,028.33 | 13,028.33 |  | 13028.3211 | HOVATER C | 1 | 1 |  | H | BILL M | 0 |  |  |  |  |  |  |  |  |  |  | 08-009 |  |
| 1212121135Ba |  | FY08 LAB/EXP Validation Testing on Cavity Phase 2A (FLD CONT) |  | 72d | 2008-12-01 A | 2009-03-20 A | 1212121135 | 100% |  |  | ELEC ENG [59.29 h]; ELEC TECH [37.06 h]; SCIENTIST [14.82 h] | 6,249.23 | 6,249.23 |  | 6055.7968 | HOVATER C | 1 | 1 |  | N/A | BILL M | 0 |  |  | 1.2.1.2.1.2.1 | EXP0809 | 09-001 |  |  |  |  |  | 08-009 | 08-016 |
| 1212121135B |  | PROC Validation Testing on Cavity Phase 2 (FLD CONT) |  | 75d | 2009-01-02 A | 2009-04-20 A | 1212121135 | 100% |  |  | PROCUREMENT<$50K 60 NO ESCALATION FY09 | 3,116.34 |  |  | 3116.338 | HOVATER C | 1 | 1 |  | N/A | BILL M | 0 |  | 09-012 | 1.2.1.2.1.2.1 | EXP0809 | 09-001 | 100 |  | 0 | 3116.34 | 311634 | 08-009 | 08-016 |
| 1212121145 |  | Update Documentation and Procurement Prep (FLD CONT)+ |  | 152d | 2009-01-26 A | 2009-08-28 A | 1212121140 FS-23d | 100% |  |  | OFFICE [80 h]; ELEC ENG [160 h]; ELEC DES [320 h] | 27,068.8 | 27,068.8 |  | 27068.8 | HOVATER C | 1 | 1 |  | H | BILL M | 0 | 07-027 |  |  |  |  |  |  |  |  |  | 08-009 |  |
| 1212121135Bb |  | FY09 LAB/EXP Validation Testing on Cavity Phase 2B (FLD CONT) |  | 22d | 2009-03-20 A | 2009-04-20 A | 1212121135Ba | 100% |  |  | SCIENTIST [44.82 h]; ELEC ENG [179.28 h]; ELEC TECH [112.05 h] | 18,896.33 | 18,896.33 |  | 18896.3361 | HOVATER C | 1 | 1 |  | N/A | BILL M | 0 |  |  | 1.2.1.2.1.2.1 | EXP0809 | 09-001 |  |  |  |  |  | 08-009 | 08-016 |
| 1212121170 |  | Pre-Constrctn Dsgn Review (FLD CONT) |  | 18d | 2009-04-27 A | 2009-05-20 A | 1212121135B, 1212121135Bb FS+15d | 100% |  |  | MECH DES [12 h]; ELEC DES [80 h]; MECH ENG [12 h]; ELEC ENG [320 h] | 25,523.8 | 25,523.8 |  | 25523.8 | HOVATER C | 1 | 1 |  | H | BILL M | 0 |  |  |  |  |  |  |  |  |  |  | 08-009 |  |
| 1212121145M |  | Documentation Ready for Procurement (FLD CONT)+ | milestone | 0d | 2009-08-28 A | 2009-08-28 A | 1212121145 | 100% | 2009-09-01 | 2009-09-01 |  |  |  |  | 0 | HOVATER C | 1 | 1 | 9 | M | BILL M |  | 07-027 |  |  |  |  |  |  |  |  |  | 08-009 |  |
| 1212121175 |  | Re-Baseline Actuals Adjustment |  | 1d | 2013-08-30 A | 2013-08-30 A |  | 100% | 2013-09-03 | 2013-09-03 | PROCUREMENT>$50K 69 NO ESCALATION | 61,971.9 |  |  | 61971.9 |  |  |  |  |  |  |  |  |  |  |  |  | 100 | ADJ | 0 | 61971.9 | 6197190 |  |  |

Notes:
- 1212113060M: Entry Criteria: Ext Pred: klystron & HPA / sufficiently defined
- 1212113075: Corrective Actions: Cost savings, HOM Filter are Internal & Activity remains to preserve / logic.
- 1212121135: Entry Criteria: Predecessor: 1212121105M (already in baseline)
- 1212121135Ba: Entry Criteria: Predecessor: 1212121105M (already in baseline)
- 1212121135B: Entry Criteria: Predecessor: 1212121105M (already in baseline)
- 1212121135Bb: Entry Criteria: Predecessor: 1212121105M (already in baseline)

| ID | WBS | Activity | Type | Duration | Start | Finish | Predecessors | Complete | Planned start | Planned finish | Resources | Cost | Actual cost | Planned FinishUDF | MONTHLY EV COST | RESP - Responsibility | STRT%COMP for CM EVM | FNSH%COMP for CM EVM | Milestone Level | EVMS Reporting Codes | CAM RESPONSIBLE | Calculated Remaining Total Cost | Remaining Material Cost Based on % Compl | Claimed Material Cost Based on % Complet | Initial Claimed Material Calc | Claimed Material Divider | CR 07-027 | CR 08-009 | CR 09-012 | CR 08-016 | WBS ASSIGNMENT | EXPNS ACT BRIDGING FY SPLIT | CR 09-001 | ReBaseline Actuals Adjustment |
| --- | --- | --- | --- | --- | --- | --- | --- | --- | --- | --- | --- | --- | --- | --- | --- | --- | --- | --- | --- | --- | --- | --- | --- | --- | --- | --- | --- | --- | --- | --- | --- | --- | --- | --- |
|  | 2 | **1.2.1.2.1.2.2 RESONANCE CONTROL & INTERLOCKS** |  |  | 2006-10-02 | 2013-08-30 |  |  |  |  |  |  |  |  |  |  |  |  |  |  |  |  |  |  |  |  |  |  |  |  |  |  |  |  |
| 1212122000M |  | Start Preliminary Integrated System Design (RESON CNTL & INTRLCKS) | milestone | 0d | 2006-10-02 A | 2006-10-02 A | 9-070M FS+60d | 100% | 2007-01-04 | 2007-01-04 |  |  |  | 2007-01-04 | 0 | HOVATER C | 1 | 1 | 9 | N/A | BILL M |  |  |  |  |  |  |  |  |  |  |  |  |  |
| 1212122005 |  | Prepare Preliminary Integrated System Design (RESON CNTL & INTRLCKS) |  | 160d | 2006-10-02 A | 2007-05-28 A | 1212122000M | 100% | 2006-10-02 | 2007-05-25 | ELEC ENG [104.4 h]; ELEC DES [34.8 h]; COMP SCIENT [69.6 h] | 12,394.45 | 12,394.45 | 2007-03-02 | 12494.244 | HOVATER C | 1 | 1 |  | N/A | BILL M | 0 |  |  |  |  |  |  |  |  |  |  |  |  |
| 1212122015 |  | Develop Detailed Preliminary Integrated System Design specification (RESON CNTL & INTRLCKS) |  | 84d | 2006-11-01 A | 2007-03-12 A | 1212122000M | 100% |  |  | ELEC ENG [34.8 h] | 2,299.24 | 2,299.24 | 2007-02-01 | 2299.236 | HOVATER C | 1 | 1 |  | N/A | BILL M | 0 |  |  |  |  |  |  |  |  |  |  |  |  |
| 1212122025 |  | Develop Interlock Preliminary Design (RESON CNTL & INTRLCKS) |  | 161d | 2007-01-02 A | 2007-08-20 A | 1212122020M | 100% |  |  | ELEC TECH [104.4 h]; ELEC DES [208.8 h]; COMP SCIENT [69.6 h]; ELEC ENG [208.8 h]; PROCUREMENT<$50K 60 | 39,137.32 | 30,675.32 | 2007-04-27 | 39658.692 | HOVATER C | 1 | 1 |  | N/A | BILL M | 0 | 0 | 8462 | 846200 | 100 |  |  |  |  |  |  |  |  |
| 1212122050 |  | Develop PZT Driver chassis Preliminary Design (RESON CNTL & INTRLCKS) |  | 147d | 2007-01-02 A | 2007-07-31 A | 1212122045M | 100% |  |  | ELEC ENG [139.2 h]; COMP SCIENT [69.6 h]; ELEC DES [174 h]; PROCUREMENT<$50K 60; ELEC TECH [104.4 h] | 31,832.02 | 24,814.02 | 2007-08-03 | 31314.24533 | HOVATER C | 1 | 1 |  | N/A | BILL M | 0 | 0 | 7018 | 701800 | 100 |  |  |  |  |  |  |  |  |
| 1212122080 |  | Update Construction Cost and Schedule (RESON CNTL & INTRLCKS) |  | 27d | 2007-03-16 A | 2007-04-23 A | 1212122075 | 100% |  |  | ELEC ENG [34.8 h] | 2,217.78 | 2,217.78 | 2007-05-31 | 2161.776 | HOVATER C | 1 | 1 |  | N/A | BILL M | 0 |  |  |  |  |  |  |  |  |  |  |  |  |
| 1212122055 |  | Build PZT Driver chassis validation unit (RESON CNTL & INTRLCKS) |  | 121d | 2007-03-26 A | 2007-09-14 A | 1212122050 | 100% | 2007-03-26 | 2007-09-13 |  |  |  | 2007-08-17 | 0 | HOVATER C | 1 | 1 |  | N/A | BILL M |  |  |  |  |  |  |  |  |  |  |  |  |  |
| 1212122075 |  | Update PED Cost and Schedule (RESON CNTL & INTRLCKS) |  | 8d | 2007-03-29 A | 2007-04-09 A | 1212122070M | 100% |  |  | ELEC ENG [34.8 h] | 2,196.14 | 2,196.14 | 2007-05-16 | 2161.776 | HOVATER C | 1 | 1 |  | N/A | BILL M | 0 |  |  |  |  |  |  |  |  |  |  |  |  |
| 1212122045M |  | Start PZT Driver chassis design (RESON CNTL & INTRLCKS) | milestone | 0d | 2007-04-02 A | 2007-04-02 A | 1212122020M FS+63d | 100% | 2007-05-03 | 2007-05-03 |  |  |  | 2007-05-03 | 0 | HOVATER C | 1 | 1 | 9 | N/A | BILL M |  |  |  |  |  |  |  |  |  |  |  |  |  |
| 1212122020M |  | Interlock and Step Chassis (RESON CNTL & INTRLCKS) | milestone | 0d | 2007-05-01 A | 2007-05-01 A | 1212122015 | 100% | 2007-02-02 | 2007-02-02 |  |  |  | 2007-02-02 | 0 | HOVATER C | 1 | 1 | 9 | N/A | BILL M |  |  |  |  |  |  |  |  |  |  |  |  |  |
| 1212122070M |  | Start Cost & Schedule Update (RESON CNTL & INTRLCKS) | milestone | 0d | 2007-05-01 A | 2007-05-01 A | 1212122010M, 1212122045M | 100% | 2007-05-03 | 2007-05-03 |  |  |  | 2007-05-03 | 0 | HOVATER C | 1 | 1 | 9 | N/A | BILL M |  |  |  |  |  |  |  |  |  |  |  |  |  |
| 1212122085M |  | Resonance Control Ready for Baseline (RESON CNTL & INTRLCKS) | milestone | 0d | 2007-05-01 A | 2007-05-01 A | 1212122080 | 100% | 2007-05-31 | 2007-05-31 |  |  |  | 2007-05-31 | 0 | HOVATER C | 1 | 1 | 5 | N/A | BILL M |  |  |  |  |  |  |  |  |  |  |  |  |  |
| 1212122030 |  | Build Design Interlock validation unit (RESON CNTL & INTRLCKS) |  | 114.5d | 2007-05-21 A | 2007-10-31 A | 1212122025 | 100% |  |  |  |  |  | 2007-05-11 | 0 | HOVATER C | 1 | 1 |  | N/A | BILL M |  |  |  |  |  |  |  |  |  |  |  |  |  |
| 1212122010M |  | Preliminary Integrated System Design Complete (RESON CNTL & INTRLCKS) | milestone | 0d | 2007-05-28 A | 2007-05-28 A | 1212122005 | 100% | 2007-03-02 | 2007-03-02 |  |  |  | 2007-03-02 | 0 | HOVATER C | 1 | 1 | 5 | N/A | BILL M |  |  |  |  |  |  |  |  |  |  |  |  |  |
| 1212122060 |  | Conduct PZT Driver chassis Validation testing (RESON CNTL & INTRLCKS) |  | 69d | 2007-07-02 A | 2007-10-08 A | 1212122055 | 100% |  |  | COMP SCIENT [69.6 h]; ELEC ENG [69.6 h]; ELEC TECH [34.8 h] | 9,439.97 | 9,439.97 | 2007-09-28 | 9569.132204 | HOVATER C | 1 | 1 |  | N/A | BILL M | 0 |  |  |  |  | 07-027 |  |  |  |  |  |  |  |
| 1212122065M |  | PZT Driver chassis Validation test complete (RESON CNTL & INTRLCKS) | milestone | 0d | 2007-10-08 A | 2007-10-08 A | 1212122060 | 100% | 2007-11-08 | 2007-11-08 |  |  |  | 2007-09-28 | 0 | HOVATER C | 1 | 1 | 5 | N/A | BILL M |  |  |  |  |  |  |  |  |  |  |  |  |  |
| 1212122035 |  | Interlock Validation Testing (RESON CNTL & INTRLCKS) |  | 8d | 2007-11-01 A | 2007-11-13 A | 1212122030 FS+55d | 100% |  |  | ELEC ENG [69.6 h]; ELEC TECH [34.8 h]; COMP SCIENT [69.6 h] | 9,714.41 | 9,714.41 | 2007-06-25 | 9504.003192 | HOVATER C | 1 | 1 |  | N/A | BILL M | 0 |  |  |  |  | 07-027 |  |  |  |  |  |  |  |
| 1212122040M |  | Interlock Validation Completed (RESON CNTL & INTRLCKS) | milestone | 0d | 2007-11-13 A | 2007-11-13 A | 1212122035 | 100% | 2008-03-13 | 2008-03-13 |  |  |  | 2007-06-25 | 0 | HOVATER C | 1 | 1 | 5 | N/A | BILL M |  |  |  |  |  |  |  |  |  |  |  |  |  |
| 1212122100 |  | Resonance & Interlock Dsgn Assessmnt (RESON CNTL & INTRLCKS) |  | 379d | 2008-01-21 A | 2009-07-27 A | 1212122095Ba FS-25d | 100% | 2008-01-22 | 2009-07-27 | ELEC TECH [160 h]; ELEC ENG [545.45 h]; ELEC DES [400 h]; PROCUREMENT<$50K 60 | 65,375.65 | 58,986.74 |  | 66242.35916 | HOVATER C | 1 | 1 |  | N/A | BILL M | 0 | 0 | 6388.91 | 638891 | 100 | 07-027 | 08-009 | 09-012 |  |  |  |  |  |
| 1212122090 |  | Resonance Cavity Tests P-1 (RESON CNTL & INTRLCKS) |  | 11d | 2008-06-02 A | 2008-06-17 A | 1212122085M, 9-080M, 1212122065M | 100% | 2008-06-02 | 2008-06-16 | ELEC TECH [24 h]; ELEC DES [24 h]; COMP SCIENT [36 h]; SUPPLIES & MATERIALS; ELEC ENG [36 h] | 6,822.79 | 6,327.48 |  | 6822.792 | HOVATER C | 1 | 1 |  | H | BILL M | 0 |  |  |  |  | 07-027 | 08-009 | 09-012 |  |  |  |  |  |
| 1212122090B |  | FY08 Resonance Cavity Tests P-2 (RESON CNTL & INTRLCKS) |  | 18d | 2008-11-03 A | 2008-11-26 A | 1212122090 FS+110d | 100% |  |  | ELEC ENG [6.94 h]; COMP SCIENT [1.36 h]; SUPPLIES & MATERIALS; ELEC TECH [1.36 h] | 677.07 | 581.6 |  | 659.0636 | HOVATER C | 1 | 1 |  | H | BILL M | 0 |  |  |  |  | 07-027 | 08-009 | 09-012 | 08-016 | 1.2.1.2.1.2.2 | EXP0809 | 09-001 |  |
| 1212122095 |  | Cavity Interlock Tests P-1(RESON CNTL & INTRLCKS) |  | 18d | 2008-11-03 A | 2008-11-26 A | 1212122040M FS+250d | 100% |  |  | COMP SCIENT [40 h]; ELEC TECH [53.34 h]; ELEC ENG [80 h]; ELEC DES [53.34 h] | 12,122.04 | 12,122.04 |  | 11746.8232 | HOVATER C | 1 | 1 |  | H | BILL M | 0 |  |  |  |  | 07-027 | 08-009 | 09-012 |  |  |  |  |  |
| 1212122090Ba |  | FY09 Resonance Cavity Tests P-2 (RESON CNTL & INTRLCKS) |  | 16d | 2008-12-01 A | 2008-12-22 A | 1212122090B | 100% |  |  | ELEC TECH [38.64 h]; SUPPLIES & MATERIALS; COMP SCIENT [38.64 h]; ELEC ENG [197.06 h] | 19,314.31 | 16,516.52 |  | 19314.317 | HOVATER C | 1 | 1 |  | H | BILL M | 0 |  |  |  |  | 07-027 | 08-009 |  | 08-016 | 1.2.1.2.1.2.2 | EXP0809 | 09-001 |  |
| 1212122095B |  | FY08 Cavity Interlock Tests P-2 (RESON CNTL & INTRLCKS) |  | 34d | 2009-02-02 A | 2009-03-20 A | 1212122095 FS-15d | 100% |  |  | COMP SCIENT [7.18 h]; ELEC TECH [7.18 h]; ELEC ENG [28.72 h] | 2,561.83 | 2,561.83 |  | 2482.5568 | HOVATER C | 1 | 1 |  | N/A | BILL M | 0 |  |  |  |  | 07-027 | 08-009 | 09-012 | 08-016 | 1.2.1.2.1.2.2 | EXP0809 | 09-001 |  |
| 1212122095Ba |  | FY09 Cavity Interlock Tests P-2 (RESON CNTL & INTRLCKS) |  | 20d | 2009-03-20 A | 2009-04-16 A | 1212122095B | 100% |  |  | COMP SCIENT [32.82 h]; ELEC TECH [32.82 h]; ELEC ENG [131.28 h] | 11,710.17 | 11,710.17 |  | 11710.176 | HOVATER C | 1 | 1 |  | N/A | BILL M | 0 |  |  |  |  | 07-027 | 08-009 |  | 08-016 | 1.2.1.2.1.2.2 | EXP0809 | 09-001 |  |
| 1212122170 |  | Pre-Constrctn Dsgn Review (RESON CNTL & INTRLCKS) |  | 42d | 2009-03-25 A | 2009-05-21 A | 1212122090Ba, 1212122095Ba | 100% |  |  | ELEC ENG [80 h]; MECH DES [12 h]; MECH ENG [12 h] | 6,430.2 | 6,430.2 |  | 6430.2 | HOVATER C | 1 | 1 |  | H | BILL M | 0 |  |  |  |  | 07-027 | 08-009 |  |  |  |  |  |  |
| 1212122105 |  | Update Documentation and Procurement Prep (RESON CNTL & INTRLCKS) |  | 108d | 2009-04-20 A | 2009-09-21 A | 1212122100 FS-23d | 100% |  |  | ELEC DES [160 h]; OFFICE [40 h]; ELEC TECH [40 h] | 10,002.8 | 10,002.8 |  | 10002.8 | HOVATER C | 1 | 1 |  | H | BILL M | 0 |  |  |  |  | 07-027 | 08-009 |  |  |  |  |  |  |
| 1212122110M |  | Documentation Ready for Prcrmnt (RESON CNTL & INTRLCKS)+ | milestone | 0d | 2009-09-21 A | 2009-09-21 A | 1212122105 | 100% | 2009-10-01 | 2009-10-01 |  |  |  |  | 0 | HOVATER C | 1 | 1 | 6 | M | BILL M |  |  |  |  |  | 07-027 | 08-009 |  |  |  |  |  |  |
| 1212122175 |  | Re-Baseline Actuals Adjustment |  | 1d | 2013-08-30 A | 2013-08-30 A |  | 100% | 2013-09-03 | 2013-09-03 | PROCUREMENT>$50K 69 NO ESCALATION | 15,067.41 |  |  | 15067.41 |  |  |  |  |  |  |  | 0 | 15067.41 | 1506741 | 100 |  |  |  |  |  |  |  | ADJ |

Notes:
- 1212122090: Entry Criteria: Ext Pred: / 1212122065M
- 1212122090B: Entry Criteria: Ext Pred: / 1212122065M
- 1212122095: Entry Criteria: Ext Pred: / 1212122040M
- 1212122090Ba: Entry Criteria: Ext Pred: / 1212122065M
- 1212122095B: Entry Criteria: Ext Pred: / 1212122040M
- 1212122095Ba: Entry Criteria: Ext Pred: / 1212122040M

| ID | WBS | Activity | Type | Duration | Start | Finish | Predecessors | Complete | Planned start | Planned finish | Resources | Cost | Actual cost | Planned FinishUDF | Remaining Material Cost Based on % Compl | Claimed Material Cost Based on % Complet | Initial Claimed Material Calc | Claimed Material Divider | Calculated Remaining Total Cost | MONTHLY EV COST | RESP - Responsibility | STRT%COMP for CM EVM | FNSH%COMP for CM EVM | EVMS Reporting Codes | CAM RESPONSIBLE | Milestone Level | CR 08-009 | CR 09-012 | CR 07-027 | ReBaseline Actuals Adjustment | CR 07-024 | Profile change |
| --- | --- | --- | --- | --- | --- | --- | --- | --- | --- | --- | --- | --- | --- | --- | --- | --- | --- | --- | --- | --- | --- | --- | --- | --- | --- | --- | --- | --- | --- | --- | --- | --- |
|  | 3 | **1.2.1.2.1.2.3 PACKAGE/INTERFACE** |  |  | 2007-02-27 | 2013-08-30 |  |  |  |  |  |  |  |  |  |  |  |  |  |  |  |  |  |  |  |  |  |  |  |  |  |  |
| 1212123005 |  | Develop Preliminary Integrated System Design (PKG/INTRFC) |  | 56d | 2007-02-27 A | 2007-05-15 A | 1212123000M | 100% |  |  | ELEC ENG [17.4 h]; ELEC DES [34.8 h]; ELEC TECH [34.8 h]; PROCUREMENT<$50K 60 | 7,173.9 | 4,073.9 | 2007-05-09 | 0 | 3100 | 310000 | 100 | 0 | 7155.3658 | HOVATER C | 1 | 1 | N/A | BILL M |  |  |  |  |  |  |  |
| 1212123020 |  | Update PED Cost and Schedule (PKG/INTRFC) |  | 32d | 2007-03-02 A | 2007-04-16 A | 1212123015M | 100% |  |  | ELEC ENG [8.7 h] | 563 | 563 | 2007-04-25 |  |  |  |  | 0 | 554.19 | HOVATER C | 1 | 1 | N/A | BILL M |  |  |  |  |  |  |  |
| 1212123025 |  | Update Construction Cost and Schedule (PKG/INTRFC) |  | 29d | 2007-03-14 A | 2007-04-23 A | 1212123020 | 100% |  |  | ELEC ENG [8.7 h] | 555.85 | 555.85 | 2007-06-07 |  |  |  |  | 0 | 540.444 | HOVATER C | 1 | 1 | N/A | BILL M |  |  |  |  |  |  |  |
| 1212123000M |  | Start Preliminary Integrated System Design (PKG/INTRFC) | milestone | 0d | 2007-04-02 A | 2007-04-02 A | 9-070M FS+108d | 100% | 2007-03-15 | 2007-03-15 |  |  |  | 2007-03-15 |  |  |  |  |  | 0 | HOVATER C | 1 | 1 | N/A | BILL M | 9 |  |  |  |  |  |  |
| 1212123015M |  | Start Cost & Schedule Update (PKG/INTRFC) | milestone | 0d | 2007-04-02 A | 2007-04-02 A | 1212123000M | 100% | 2007-03-15 | 2007-03-15 |  |  |  | 2007-03-15 |  |  |  |  |  | 0 | HOVATER C | 1 | 1 | N/A | BILL M | 9 |  |  |  |  |  |  |
| 1212123030M |  | Racks-Interface Ready for Baseline (PKG/INTRFC) | milestone | 0d | 2007-04-23 A | 2007-04-23 A | 1212123025, 1212123010M | 100% | 2007-06-07 | 2007-06-07 |  |  |  | 2007-06-07 |  |  |  |  |  | 0 | HOVATER C | 1 | 1 | N/A | BILL M | 5 |  |  |  |  |  |  |
| 1212123010M |  | Preliminary Integrated Design Complete (PKG/INTRFC) | milestone | 0d | 2007-05-15 A | 2007-05-15 A | 1212123005 | 100% | 2007-05-09 | 2007-05-09 |  |  |  | 2007-05-09 |  |  |  |  |  | 0 | HOVATER C | 1 | 1 | N/A | BILL M | 5 |  |  |  |  |  |  |
| 1212123035 |  | Dsgn Chassis Pwr Supply (PKG/INTRFC) |  | 28d | 2007-12-03 A | 2008-01-21 A | 9-080M | 100% | 2007-12-03 | 2008-01-18 | ELEC DES [160 h]; ELEC TECH [80 h]; SUPPLIES & MATERIALS; ELEC ENG [80 h]; PROCUREMENT<$50K 60 | 22,671.91 | 15,221.6 |  | 0 | 5324.6 | 532460 | 100 | 0 | 22671.918 | HOVATER C | 1 | 1 | N/A | BILL M |  |  |  |  |  |  |  |
| 1212123040 |  | Proc & Test PS P-1 (PKG/INTRFC) |  | 5d | 2008-01-21 A | 2008-01-28 A | 1212123035 | 100% | 2008-01-22 | 2008-01-28 | ELEC DES [110.4 h]; ELEC TECH [55.2 h]; ELEC ENG [36.8 h] | 9,357.69 | 9,357.69 |  |  |  |  |  | 0 | 9357.688 | HOVATER C | 1 | 1 | N/A | BILL M |  | 08-009 | 09-012 |  |  |  |  |
| 1212123040B |  | Proc & Test PS P-2 (PKG/INTRFC) |  | 173d | 2008-01-28 A | 2008-09-30 A | 1212123040 FS+50d | 100% |  |  | ELEC DES [129.6 h]; ELEC TECH [64.8 h]; PROCUREMENT<$50K 60; ELEC ENG [43.2 h] | 15,246.86 | 10,985.11 |  | 0 | 4261.75 | 426175 | 100 | 0 | 15246.859 | HOVATER C | 1 | 1 | N/A | BILL M |  | 08-009 |  |  |  |  |  |
| 1212123045 |  | Final Dsgn Rack Layout with FC, Res & PS (PKG/INTRFC) |  | 208d | 2008-04-25 A | 2009-02-27 A | 1212123030M, 1212123040B | 100% |  |  | ELEC ENG [80 h]; ELEC DES [240 h]; ELEC TECH [160 h]; PROCUREMENT<$50K 60 | 26,811.83 | 22,230.19 |  | 0 | 4581.64 | 458164 | 100 | 0 | 26481.64 | HOVATER C | 1 | 1 | H | BILL M |  | 08-009 | 09-012 |  |  |  |  |
| 1212123050 |  | Update Documentation and Procurement Prep(PKG/INTRFC) |  | 134d | 2009-02-23 A | 2009-08-31 A | 1212123045 | 100% |  |  | ELEC DES [240 h]; OFFICE [80 h]; ELEC ENG [40 h] | 15,682.8 | 15,682.8 |  |  |  |  |  | 0 | 15682.8 | HOVATER C | 1 | 1 | H | BILL M |  | 08-009 |  | 07-027 |  |  |  |
| 1212123170 |  | Pre-Constrctn Dsgn Review (PKG/INTRFC) |  | 42d | 2009-03-25 A | 2009-05-21 A | 1212123045 FS+40d | 100% |  |  | ELEC DES [40 h]; ELEC ENG [40 h]; MECH DES [12 h]; MECH ENG [12 h] | 5,700.2 | 5,700.2 |  |  |  |  |  | 0 | 5700.2 | HOVATER C | 1 | 1 | H | BILL M |  | 08-009 |  | 07-027 |  |  |  |
| 1212123055M |  | Rack Documentation Ready for Prcrmnt (PKG/INTRFC)+ | milestone | 0d | 2009-08-31 A | 2009-08-31 A | 1212123050 | 100% | 2009-09-30 | 2009-09-30 |  |  |  |  |  |  |  |  |  | 0 | HOVATER C | 1 | 1 | M | BILL M | 6 | 08-009 |  | 07-027 |  |  |  |
| 1212123175 |  | Re-Baseline Actuals Adjustment |  | 1d | 2013-08-30 A | 2013-08-30 A |  | 100% | 2013-09-03 | 2013-09-03 | PROCUREMENT>$50K 69 NO ESCALATION | 10,260.64 |  |  | 0 | 10260.64 | 1026064 | 100 |  | 10260.64 |  |  |  |  |  |  |  |  |  | ADJ |  |  |
|  | 4 | **1.2.1.2.1.2.4 CPU & SOFTWARE** |  |  | 2007-01-02 | 2013-08-30 |  |  |  |  |  |  |  |  |  |  |  |  |  |  |  |  |  |  |  |  |  |  |  |  |  |  |
| 1212124000M |  | Start Preliminary Integrated System Design (CPU & SW)100 | milestone | 0d | 2007-01-02 A | 2007-01-02 A | 9-070M FS+22d | 100% | 2006-11-01 | 2006-11-01 |  |  |  | 2006-11-01 |  |  |  |  |  | 0 | HOVATER C | 1 | 1 | N/A | BILL M | 9 |  |  |  |  |  |  |
| 1212124005 |  | Develop Preliminary Integrated System Design (CPU & SW)100 |  | 79d | 2007-01-02 A | 2007-04-24 A | 1212124000M | 100% |  |  | ELEC ENG [69.6 h]; COMP SCIENT [69.6 h] | 8,573.39 | 8,573.39 | 2007-03-06 |  |  |  |  | 0 | 8629.704 | HOVATER C | 1 | 1 | N/A | BILL M |  |  |  |  |  |  |  |
| 1212124025 |  | Develop Preliminary Embedded IOC Design (CPU & SW)85 |  | 108d | 2007-02-28 A | 2007-07-31 A | 1212124020M | 100% |  |  | PROCUREMENT<$50K 60; ELEC ENG [29.6 h]; COMP SCIENT [118.4 h]; ELEC TECH [29.6 h] | 14,234.61 | 9,848.61 | 2007-03-28 | 0 | 4386 | 438600 | 100 | 0 | 14425.432 | HOVATER C | 1 | 1 | N/A | BILL M |  |  |  |  |  | 07-024 |  |
| 1212124050 |  | Update PED Cost and Schedule (CPU & SW)100 |  | 31d | 2007-03-05 A | 2007-04-16 A | 1212124045M | 100% |  |  | ELEC ENG [17.4 h] | 1,125.23 | 1,125.23 | 2007-04-30 |  |  |  |  | 0 | 1080.888 | HOVATER C | 1 | 1 | N/A | BILL M |  |  |  |  |  |  |  |
| 1212124055 |  | Update Construction Cost and Schedule (CPU & SW)100 |  | 30d | 2007-03-13 A | 2007-04-23 A | 1212124050, 1212124015 | 100% |  |  | ELEC ENG [17.4 h] | 1,112.96 | 1,112.96 | 2007-05-28 |  |  |  |  | 0 | 1080.888 | HOVATER C | 1 | 1 | N/A | BILL M |  |  |  |  |  |  |  |
| 1212124020M |  | Start Embedded IOC Design (CPU & SW)100 | milestone | 0d | 2007-04-02 A | 2007-04-02 A | 1212124000M FS+36d | 100% | 2007-01-02 | 2007-01-02 |  |  |  | 2007-01-02 |  |  |  |  |  | 0 | HOVATER C | 1 | 1 | N/A | BILL M | 9 |  |  |  |  |  |  |
| 1212124015 |  | Refine Embedded IOC Detailed specification (CPU & SW)30 |  | 70d | 2007-04-23 A | 2007-07-31 A | 1212124010M | 100% |  |  | ELEC ENG [10.4 h] | 640.42 | 640.42 | 2007-04-03 |  |  |  |  | 0 | 683.02 | HOVATER C | 1 | 1 | N/A | BILL M |  |  |  |  |  | 07-024 |  |
| 1212124045M |  | Start Cost & Schedule Update (CPU & SW)100 | milestone | 0d | 2007-04-23 A | 2007-04-23 A | 1212124000M FS+99d | 100% | 2007-04-03 | 2007-04-03 |  |  |  | 2007-04-03 |  |  |  |  |  | 0 | HOVATER C | 1 | 1 | N/A | BILL M | 9 |  |  |  |  |  |  |
| 1212124060M |  | Controls Ready for Baseline (CPU & SW)100 | milestone | 0d | 2007-04-23 A | 2007-04-23 A | 1212124055 | 100% | 2007-05-29 | 2007-05-29 |  |  |  | 2007-05-28 |  |  |  |  |  | 0 | HOVATER C | 1 | 1 | N/A | BILL M | 5 |  |  |  |  |  |  |
| 1212124010M |  | Preliminary Integrated Design Complete (CPU & SW)100 | milestone | 0d | 2007-04-24 A | 2007-04-24 A | 1212124005 | 100% | 2007-03-06 | 2007-03-06 |  |  |  | 2007-03-06 |  |  |  |  |  | 0 | HOVATER C | 1 | 1 | N/A | BILL M | 5 |  |  |  |  |  |  |
| 1212124065 |  | Program EPICS Interface P-1 (CPU&SW) |  | 13d | 2008-01-02 A | 2008-01-21 A | 9-080M, 1212124040M | 100% | 2008-01-02 | 2008-01-18 |  |  |  |  |  |  |  |  |  | 0 | HOVATER C | 1 | 1 | N/A | BILL M |  | 08-009 | 09-012 |  |  | 07-024 |  |
| 1212124030M |  | Start Validation Unit Testing (CPU & SW) | milestone | 0d | 2008-01-07 A | 2008-01-07 A | 1212124025 | 100% | 2008-02-01 | 2008-02-01 |  |  |  | 2007-03-29 |  |  |  |  |  | 0 | HOVATER C | 1 | 1 | N/A | BILL M | 9 |  |  |  |  |  |  |
| 1212124035 |  | Conduct Validation Testing w Digital Board (CPU & SW) |  | 58d | 2008-01-07 A | 2008-03-28 A | 1212121055M, 1212124030M | 100% |  |  | SUPPLIES & MATERIALS; ELEC ENG [160 h] | 10,958.4 | 9,958.4 | 2007-09-25 |  |  |  |  | 0 | 10939.2 | HOVATER C | 1 | 1 | N/A | BILL M |  |  | 09-012 | 07-027 |  | 07-024 |  |
| 1212124065B |  | Program EPICS Interface P-2 (CPU&SW) |  | 275d | 2008-01-22 A | 2009-02-27 A | 1212124065 FS+120d | 100% |  |  |  |  |  |  |  |  |  |  |  | 0 | HOVATER C | 1 | 1 | N/A | BILL M |  | 08-009 | 09-012 |  |  | 07-024 |  |
| 1212124040M |  | CPU & Software Validation Tests | milestone | 0d | 2008-03-28 A | 2008-03-28 A | 1212124060M, 1212124035 | 100% | 2008-04-28 | 2008-04-28 |  |  |  | 2007-09-25 |  |  |  |  |  | 0 | HOVATER C | 1 | 1 | N/A | BILL M | 5 |  |  | 07-027 |  |  |  |
| 1212124070M |  | EPICS Ready for Test (CPU&SW) | milestone | 0d | 2009-02-27 A | 2009-02-27 A | 1212124065B | 100% | 2009-04-28 | 2009-04-28 |  |  |  |  |  |  |  |  |  | 0 | HOVATER C | 1 | 1 | M | BILL M | 6 | 08-009 |  |  |  |  |  |
| 1212124075 |  | Cavity Tests & Modifications (CPU&SW) |  | 19d | 2009-03-25 A | 2009-04-20 A | 1212124070M | 100% |  |  |  |  |  |  |  |  |  |  |  | 0 | HOVATER C | 1 | 1 | Z | BILL M |  | 08-009 | 09-012 |  |  | 07-024 |  |
| 1212124170 |  | Pre-Constrctn Dsgn Review (CPU&SW)++ |  | 41d | 2009-03-25 A | 2009-05-20 A | 1212124080M | 100% |  |  |  |  |  |  |  |  |  |  |  | 0 | HOVATER C | 1 | 1 | Z | BILL M |  | 08-009 | 09-012 |  |  | 07-024 | C |
| 1212124080M |  | CPU & Software tested on Cavity (CPU&SW)++ | milestone | 0d | 2009-04-20 A | 2009-04-20 A | 1212124075 | 100% | 2009-06-10 | 2009-06-10 |  |  |  |  |  |  |  |  |  | 0 | HOVATER C | 1 | 1 | M | BILL M | 6 | 08-009 |  |  |  |  |  |
| 1212124175 |  | Re-Baseline Actuals Adjustment |  | 1d | 2013-08-30 A | 2013-08-30 A |  | 100% | 2013-09-03 | 2013-09-03 | PROCUREMENT>$50K 69 NO ESCALATION | -24,599.59 |  |  |  |  |  | 100 |  |  |  |  |  |  |  |  |  |  |  | ADJ |  |  |

Notes:
- 1212123035: Entry Criteria: Ext Pred: / 1212123010M
- 1212123045: Entry Criteria: Ext Pred: / 1212123010M
- 1212124065: Entry Criteria: Ext Pred: / 1212124040M
- 1212124065B: Entry Criteria: Ext Pred: / 1212124040M

| ID | WBS | Activity | Type | Duration | Start | Finish | Predecessors | Complete | Planned start | Planned finish | Resources | Cost | Actual cost | Planned FinishUDF | MONTHLY EV COST | RESP - Responsibility | STRT%COMP for CM EVM | FNSH%COMP for CM EVM | Milestone Level | EVMS Reporting Codes | CAM RESPONSIBLE | Calculated Remaining Total Cost | CR 07-024 | CR 07-027 | CR 08-009 | CR 09-012 | Remaining Material Cost Based on % Compl | Claimed Material Cost Based on % Complet | Initial Claimed Material Calc | Claimed Material Divider | ReBaseline Actuals Adjustment | CR 08-016 | WBS ASSIGNMENT | EXPNS ACT BRIDGING FY SPLIT | CR 09-001 |
| --- | --- | --- | --- | --- | --- | --- | --- | --- | --- | --- | --- | --- | --- | --- | --- | --- | --- | --- | --- | --- | --- | --- | --- | --- | --- | --- | --- | --- | --- | --- | --- | --- | --- | --- | --- |
|  | 5 | **1.2.1.2.1.2.5 TEST STAND** |  |  | 2007-04-02 | 2013-08-30 |  |  |  |  |  |  |  |  |  |  |  |  |  |  |  |  |  |  |  |  |  |  |  |  |  |  |  |  |  |
| 1212125000M |  | Start Cost & Schedule Update (TEST STAND) | milestone | 0d | 2007-04-02 A | 2007-04-02 A | 9-070M FS+108d | 100% | 2007-03-15 | 2007-03-15 |  |  |  | 2007-03-15 | 0 | HOVATER C | 1 | 1 | 9 | N/A | BILL M |  |  |  |  |  |  |  |  |  |  |  |  |  |  |
| 1212125005 |  | Update PED Cost and Schedule (TEST STAND) |  | 11d | 2007-04-02 A | 2007-04-16 A | 1212125000M | 100% |  |  | ELEC ENG [8.7 h] | 540.44 | 540.44 | 2007-04-25 | 554.19 | HOVATER C | 1 | 1 |  | N/A | BILL M | 0 |  |  |  |  |  |  |  |  |  |  |  |  |  |
| 1212125010 |  | Update Construction Cost and Schedule (TEST STAND) |  | 6d | 2007-04-16 A | 2007-04-23 A | 1212125005 | 100% |  |  | ELEC ENG [8.7 h] | 540.44 | 540.44 | 2007-06-07 | 540.444 | HOVATER C | 1 | 1 |  | N/A | BILL M | 0 |  |  |  |  |  |  |  |  |  |  |  |  |  |
| 1212125015M |  | Test Stand Ready for Baseline (TEST STAND) | milestone | 0d | 2007-04-23 A | 2007-04-23 A | 1212125010 | 100% | 2007-06-07 | 2007-06-07 |  |  |  | 2007-06-07 | 0 | HOVATER C | 1 | 1 | 9 | N/A | BILL M |  |  |  |  |  |  |  |  |  |  |  |  |  |  |
| 1212125020 |  | Dsgn & Fab RF Test Stand (Test STAND)-seeNotebook Entry |  | 409d | 2008-01-14 A | 2009-08-31 A | 9-080M FS+125d, 1212125015M FS+180d | 100% |  |  |  |  |  |  | 0 | HOVATER C | 1 | 1 |  | N/A | BILL M |  | 07-024 | 07-027 | 08-009 | 09-012 |  |  |  |  |  |  |  |  |  |
| 1212125025M |  | RF Test Stand Ready for Production Tests (TEST STAND)+ | milestone | 0d | 2009-08-31 A | 2009-08-31 A | 1212125020 | 100% | 2009-09-30 | 2009-09-30 |  |  |  |  | 0 | HOVATER C | 1 | 1 | 6 | M | BILL M |  |  | 07-027 | 08-009 |  |  |  |  |  |  |  |  |  |  |
| 1212125030 |  | Re-Baseline Actuals Adjustment |  | 1d | 2013-08-30 A | 2013-08-30 A |  | 100% | 2013-09-03 | 2013-09-03 | PROCUREMENT>$50K 69 NO ESCALATION | 611.6 |  |  | 611.6 |  |  |  |  |  |  |  |  |  |  |  | 0 | 611.6 | 61160 | 100 | ADJ |  |  |  |  |
|  | 6 | **1.2.1.2.1.2.6 MASTER OSCILLATOR** |  |  | 2007-04-02 | 2013-08-30 |  |  |  |  |  |  |  |  |  |  |  |  |  |  |  |  |  |  |  |  |  |  |  |  |  |  |  |  |  |
| 1212126000M |  | Start Cost & Schedule Update (MSTR OSC) | milestone | 0d | 2007-04-02 A | 2007-04-02 A | 9-070M FS+108d | 100% | 2007-03-15 | 2007-03-15 |  |  |  | 2007-03-15 | 0 | HOVATER C | 1 | 1 | 9 | N/A | BILL M |  |  |  |  |  |  |  |  |  |  |  |  |  |  |
| 1212126005 |  | Update PED Cost and Schedule (MSTR OSC) |  | 11d | 2007-04-02 A | 2007-04-16 A | 1212126000M | 100% |  |  | ELEC ENG [8.7 h] | 540.44 | 540.44 | 2007-04-25 | 554.19 | HOVATER C | 1 | 1 |  | N/A | BILL M | 0 |  |  |  |  |  |  |  |  |  |  |  |  |  |
| 1212126010 |  | Update Construction Cost and Schedule (MSTR OSC) |  | 6d | 2007-04-16 A | 2007-04-23 A | 1212126005 | 100% |  |  | ELEC ENG [8.7 h] | 540.44 | 540.44 | 2007-06-07 | 540.444 | HOVATER C | 1 | 1 |  | N/A | BILL M | 0 |  |  |  |  |  |  |  |  |  |  |  |  |  |
| 1212126015M |  | MO Ready for Baseline (MSTR OSC) | milestone | 0d | 2007-04-23 A | 2007-04-23 A | 1212126010 | 100% | 2007-06-07 | 2007-06-07 |  |  |  | 2007-06-07 | 0 | HOVATER C | 1 | 1 | 5 | N/A | BILL M |  |  |  |  |  |  |  |  |  |  |  |  |  |  |
| 1212126170 |  | Pre-Constrctn Dsgn Review (MSTR OSC) |  | 41d | 2009-03-25 A | 2009-05-20 A | 1212126015M FS+515d, 1212126010 | 100% |  |  |  |  |  | 2007-06-14 | 0 | HOVATER C | 1 | 1 |  | Z | BILL M |  |  |  |  | 09-012 |  |  |  |  |  |  |  |  |  |
| 1212126175 |  | Re-Baseline Actuals Adjustment |  | 1d | 2013-08-30 A | 2013-08-30 A |  | 100% | 2013-09-03 | 2013-09-03 | PROCUREMENT>$50K 69 NO ESCALATION | 887.72 |  |  | 887.72 |  |  |  |  |  |  |  |  |  |  |  | 0 | 887.72 | 88772 | 100 | ADJ |  |  |  |  |
|  | 7 | **1.2.1.2.1.2.7 HPA CONTROL** |  |  | 2007-04-02 | 2013-08-30 |  |  |  |  |  |  |  |  |  |  |  |  |  |  |  |  |  |  |  |  |  |  |  |  |  |  |  |  |  |
| 1212127000M |  | Start Preliminary Integrated System Design (HPA CNTRL) | milestone | 0d | 2007-04-02 A | 2007-04-02 A | 9-070M FS+22d | 100% | 2006-11-01 | 2006-11-01 |  |  |  | 2006-11-01 | 0 | HOVATER C | 1 | 1 | 9 | N/A | BILL M |  |  |  |  |  |  |  |  |  |  |  |  |  |  |
| 1212127005 |  | Develop Preliminary System Design (HPA CNTRL) |  | 104d | 2007-04-02 A | 2007-08-27 A | 1212127000M | 100% |  |  | ELEC ENG [34.8 h]; ELEC DES [17.6 h] | 2,917.07 | 2,917.07 | 2007-01-22 | 3090.884 | HOVATER C | 1 | 1 |  | N/A | BILL M | 0 |  |  |  | 09-012 |  |  |  |  |  |  |  |  |  |
| 1212127020M |  | Start Cost & Schedule Update (HPA CNTRL) | milestone | 0d | 2007-04-02 A | 2007-04-02 A | 9-070M FS+121d | 100% | 2007-04-03 | 2007-04-03 |  |  |  | 2007-04-03 | 0 | HOVATER C | 1 | 1 | 9 | N/A | BILL M |  |  |  |  |  |  |  |  |  |  |  |  |  |  |
| 1212127025 |  | Update PED Cost and Schedule (HPA CNTRL) |  | 11d | 2007-04-02 A | 2007-04-16 A | 1212127020M | 100% |  |  | ELEC ENG [17.4 h] | 1,080.89 | 1,080.89 | 2007-04-30 | 1080.888 | HOVATER C | 1 | 1 |  | N/A | BILL M | 0 |  |  |  |  |  |  |  |  |  |  |  |  |  |
| 1212127030 |  | Update Construction Cost and Schedule (HPA CNTRL) |  | 6d | 2007-04-16 A | 2007-04-23 A | 1212127025 | 100% |  |  | ELEC ENG [17.4 h] | 1,080.89 | 1,080.89 | 2007-05-28 | 1080.888 | HOVATER C | 1 | 1 |  | N/A | BILL M | 0 |  |  |  |  |  |  |  |  |  |  |  |  |  |
| 1212127035M |  | HPA Controls Ready for Baseline (HPA CNTRL) | milestone | 0d | 2007-04-23 A | 2007-04-23 A | 1212127030, 1212127010M | 100% | 2007-05-29 | 2007-05-29 |  |  |  | 2007-05-28 | 0 | HOVATER C | 1 | 1 | 5 | N/A | BILL M |  |  |  |  |  |  |  |  |  |  |  |  |  |  |
| 1212127010M |  | Preliminary Design Complete (HPA CNTRL) | milestone | 0d | 2007-08-27 A | 2007-08-27 A | 1212127005 | 100% | 2007-11-12 | 2007-11-12 |  |  |  | 2007-01-22 | 0 | HOVATER C | 1 | 1 | 5 | N/A | BILL M |  |  |  |  |  |  |  |  |  |  |  |  |  |  |
| 1212127015 |  | Develop Detailed specification P-1 (HPA CNTRL) |  | 13d | 2007-11-01 A | 2007-11-19 A | 1212127000M, 1212112090M | 100% |  |  | ELEC ENG [8.9 h] | 553.94 | 553.94 | 2006-11-30 | 553.936 | HOVATER C | 1 | 1 |  | N/A | BILL M | 0 |  | 07-027 | 08-009 |  |  |  |  |  |  |  |  |  |  |
| 1212127015B |  | Develop Detailed specification P-2 (HPA CNTRL) |  | 15d | 2007-12-03 A | 2007-12-21 A | 1212127015 | 100% |  |  | ELEC ENG [8.5 h] | 529.04 | 529.04 | 2006-11-30 | 529.04 | HOVATER C | 1 | 1 |  | N/A | BILL M | 0 |  | 07-027 | 08-009 |  |  |  |  |  |  |  |  |  |  |
| 1212127040 |  | Dsgn HPA Control Board & Chassis (HPA CNTL) |  | 117d | 2008-01-14 A | 2008-06-30 A | 9-080M, 1212127015B, 1212127035M | 100% | 2008-01-14 | 2008-06-27 | ELEC TECH [160 h]; SUPPLIES & MATERIALS; PROCUREMENT<$50K 60; ELEC ENG [160 h]; ELEC DES [400 h] | 38,475.33 | 34,007.2 |  | 38475.327 | HOVATER C | 1 | 1 |  | N/A | BILL M | 0 |  |  | 08-009 |  | 0 | 3405.27 | 340527 | 100 |  |  |  |  |  |
| 1212127045 |  | PROC Test & Validate Dsgn (HPA CNTL) |  | 192d | 2008-04-16 A | 2009-01-26 A | 1212127040 FS+10d | 100% |  |  | PROCUREMENT<$50K 60 NO ESCALATION FY09 | 5,324.6 |  |  | 5324.604 | HOVATER C | 1 | 1 |  | H | BILL M | 0 |  |  | 08-009 | 09-012 | 0 | 5324.6 | 532460 | 100 |  | 08-016 | 1.2.1.2.1.2.7 | EXP0809 | 09-001 |
| 1212127045a |  | FY08 LAB/EXP Test & Validate Dsgn (HPA CNTL) |  | 117d | 2008-04-16 A | 2008-09-30 A | 1212127040 FS+10d | 100% |  |  | ELEC TECH [21.44 h]; COMP SCIENT [26.8 h]; ELEC DES [53.61 h]; ELEC ENG [16.08 h]; SUPPLIES & MATERIALS | 5,917.17 | 5,774.73 |  | 5917.1599 | HOVATER C | 1 | 1 |  | H | BILL M | 0 |  |  | 08-009 |  |  |  |  |  |  | 08-016 | 1.2.1.2.1.2.7 | EXP0809 | 09-001 |
| 1212127045b |  | FY09 LAB/EXP Test & Validate Dsgn (HPA CNTL) |  | 82d | 2008-09-22 A | 2009-01-26 A | 1212127045a | 100% |  |  | ELEC DES [346.39 h]; ELEC ENG [103.92 h]; ELEC TECH [138.56 h]; SUPPLIES & MATERIALS; COMP SCIENT [173.2 h] | 39,357.49 | 38,407.72 |  | 39459.291 | HOVATER C | 1 | 1 |  | H | BILL M | 0 |  |  | 08-009 |  |  |  |  |  |  | 08-016 | 1.2.1.2.1.2.7 | EXP0809 | 09-001 |
| 1212127055 |  | Assess & Modify Dsgn (HPA CNTL) |  | 106d | 2009-01-26 A | 2009-06-24 A | 1212127050M | 100% |  |  | ELEC ENG [40 h]; ELEC DES [160 h] | 9,926 | 9,926 |  | 9926 | HOVATER C | 1 | 1 |  | H | BILL M | 0 |  |  | 08-009 |  |  |  |  |  |  |  |  |  |  |
| 1212127050M |  | HPA Control Dsgn Tested (HPA CNTL) | milestone | 0d | 2009-01-26 A | 2009-01-26 A | 1212127045, 1212127045b | 100% | 2009-03-27 | 2009-03-27 |  |  |  |  | 0 | HOVATER C | 1 | 1 | 6 | M | BILL M |  |  |  | 08-009 |  |  |  |  |  |  |  |  |  |  |
| 1212127170 |  | Pre-Constrctn Dsgn Review (HPA CNTL) + |  | 18d | 2009-04-28 A | 2009-05-21 A | 1212127050M FS+64d | 100% |  |  | MECH ENG [12 h]; ELEC ENG [80 h]; MECH DES [12 h] | 6,430.2 | 6,430.2 |  | 6430.2 | HOVATER C | 1 | 1 |  | H | BILL M | 0 |  | 07-027 | 08-009 |  |  |  |  |  |  |  |  |  |  |
| 1212127060 |  | Update Documentation and Procurement Prep (HPA CNTL) |  | 60d | 2009-05-01 A | 2009-07-27 A | 1212127055 FS-45d | 100% |  |  | ELEC ENG [40 h]; ELEC DES [160 h] | 9,926 | 9,926 |  | 9926 | HOVATER C | 1 | 1 |  | H | BILL M | 0 |  |  | 08-009 |  |  |  |  |  |  |  |  |  |  |
| 1212127065M |  | HPA control Documentation Ready for Prcrmnt (HPA CNTL)++ | milestone | 0d | 2009-07-27 A | 2009-07-27 A | 1212127060 | 100% | 2009-08-03 | 2009-08-03 |  |  |  |  | 0 | HOVATER C | 1 | 1 | 6 | M | BILL M |  |  |  | 08-009 |  |  |  |  |  |  |  |  |  |  |
| 1212127175 |  | Re-Baseline Actuals Adjustment |  | 1d | 2013-08-30 A | 2013-08-30 A |  | 100% | 2013-09-03 | 2013-09-03 | PROCUREMENT>$50K 69 NO ESCALATION | -15,117.29 |  |  |  |  |  |  |  |  |  |  |  |  |  |  |  |  |  | 100 | ADJ |  |  |  |  |

Notes:
- 1212125020: Entry Criteria: Ext Pred: / 1212125015M
- 1212127040: Entry Criteria: Ext Pred: / 1212127010M

| ID | WBS | Activity | Type | Duration | Start | Finish | Predecessors | Complete | Planned start | Planned finish | Resources | Cost | Actual cost | Planned FinishUDF | MONTHLY EV COST | RESP - Responsibility | STRT%COMP for CM EVM | FNSH%COMP for CM EVM | Milestone Level | EVMS Reporting Codes | CAM RESPONSIBLE | Calculated Remaining Total Cost | CR 07-027 | Profile change | Remaining Material Cost Based on % Compl | Claimed Material Cost Based on % Complet | Initial Claimed Material Calc | Claimed Material Divider | ReBaseline Actuals Adjustment |
| --- | --- | --- | --- | --- | --- | --- | --- | --- | --- | --- | --- | --- | --- | --- | --- | --- | --- | --- | --- | --- | --- | --- | --- | --- | --- | --- | --- | --- | --- |
|  | 3 | **1.2.1.2.1.3 INSTALLATION (PED)** |  |  |  |  |  |  |  |  |  |  |  |  |  |  |  |  |  |  |  |  |  |  |  |  |  |  |  |
|  | 4 | **1.2.1.2.1.4 SYSTEM OPERATION** |  |  |  |  |  |  |  |  |  |  |  |  |  |  |  |  |  |  |  |  |  |  |  |  |  |  |  |
|  | 2 | **1.2.1.2.2 MAGNET POWER** |  |  | 2006-10-02 | 2013-08-30 |  |  |  |  |  |  |  |  |  |  |  |  |  |  |  |  |  |  |  |  |  |  |  |
|  | 1 | **1.2.1.2.2.1 BOX SUPPLIES - PED** |  |  | 2006-10-02 | 2013-08-30 |  |  |  |  |  |  |  |  |  |  |  |  |  |  |  |  |  |  |  |  |  |  |  |
| 121221000M |  | Begin Box PS PED (BOX SUP) | milestone | 0d | 2006-10-02 A | 2006-10-02 A | 9-070M | 100% |  |  |  |  |  | 2006-10-02 | 0 | MERZ B | 1 | 1 | 9 | N/A | BILL M |  |  |  |  |  |  |  |  |
| 121221005 |  | Conduct Spec & Cost Review of Other Projects (BOX SUP) |  | 135d | 2006-10-02 A | 2007-04-20 A | 121221000M | 100% |  |  | ELEC ENG [139.2 h] | 9,135.85 | 9,135.85 | 2006-11-10 | 9196.944 | MERZ B | 1 | 1 |  | N/A | BILL M | 0 |  |  |  |  |  |  |  |
| 121221015 |  | Refine/Update Preliminary Performance Requirements (BOX SUP) |  | 111d | 2006-11-01 A | 2007-04-18 A | 121221005, 121221010 | 100% |  |  | ELEC ENG [34.8 h] | 2,283.14 | 2,283.14 | 2006-12-12 | 2299.236 | MERZ B | 1 | 1 |  | N/A | BILL M | 0 |  |  |  |  |  |  |  |
| 121221025M |  | Begin Preliminary Design Box Power Supplies (BOX SUP) | milestone | 0d | 2007-01-02 A | 2007-01-02 A | 121221020M | 100% | 2006-12-13 | 2006-12-13 |  |  |  | 2006-12-13 | 0 | MERZ B | 1 | 1 | 9 | N/A | BILL M |  |  |  |  |  |  |  |  |
| 121221030 |  | Develop Preliminary PS Design (BOX SUP) |  | 78d | 2007-01-02 A | 2007-04-23 A | 121221025M | 100% |  |  | ELEC DES [139.2 h]; COMP SCIENT [104.4 h]; ELEC ENG [174 h]; ELEC TECH [34.8 h] | 25,093.27 | 25,093.27 | 2007-02-01 | 25245.66 | MERZ B | 1 | 1 |  | N/A | BILL M | 0 |  |  |  |  |  |  |  |
| 121221035 |  | Review & Revise PS Re-use Plan & Cost Estimate (BOX SUP) |  | 77d | 2007-01-02 A | 2007-04-20 A | 121221030 | 100% |  |  | ELEC DES [69.6 h]; ELEC TECH [69.6 h]; ELEC ENG [13.92 h] | 6,893 | 6,893 | 2007-03-02 | 6933.1344 | MERZ B | 1 | 1 |  | N/A | BILL M | 0 |  |  |  |  |  |  |  |
| 121221050 |  | Update Cost and Labor Estimates (BOX SUP) |  | 70d | 2007-01-15 A | 2007-04-24 A | 121221045M | 100% | 2007-01-16 | 2007-04-24 | ELEC ENG [69.6 h] | 4,531.71 | 4,531.71 | 2007-04-20 | 4392.282 | MERZ B | 1 | 1 |  | N/A | BILL M | 0 |  |  |  |  |  |  |  |
| 121221065 |  | Investigate Potential Vendors to Develop Bidders list (BOX SUP) |  | 152d | 2007-01-15 A | 2007-08-20 A | 121221055 | 100% | 2007-01-16 | 2007-08-20 | ELEC ENG [34.8 h] | 2,195.25 | 2,195.25 | 2007-06-18 | 2161.776 | MERZ B | 1 | 1 |  | N/A | BILL M | 0 |  |  |  |  |  |  |  |
| 121221010 |  | Travel _ Visit Other Projects (BOX SUP) |  | 106d | 2007-03-02 A | 2007-07-31 A | 121221000M | 100% |  |  | TRAVEL | 10,320 |  | 2006-11-10 | 10320 | MERZ B | 1 | 1 |  | N/A | BILL M | 0 |  |  |  |  |  |  |  |
| 121221055 |  | Update Resource Loaded Schedule (BOX SUP) |  | 38d | 2007-03-02 A | 2007-04-24 A | 121221050 | 100% |  |  | ELEC ENG [69.6 h] | 4,475.48 | 4,475.48 | 2007-05-18 | 4323.552 | MERZ B | 1 | 1 |  | N/A | BILL M | 0 |  |  |  |  |  |  |  |
| 121221040 |  | Prepare & Conduct Preliminary Design & Safety Review (BOX SUP) |  | 30d | 2007-04-09 A | 2007-05-18 A | 121221035 | 100% |  |  | ELEC ENG [34.8 h]; TRAVEL | 17,641.78 | 2,161.78 | 2007-03-23 | 17779.236 | MERZ B | 1 | 1 |  | N/A | BILL M | 0 |  |  |  |  |  |  |  |
| 121221020M |  | Preliminary Preformance Requirements Update Complete (BOX SUP) | milestone | 0d | 2007-04-18 A | 2007-04-18 A | 121221015 | 100% | 2006-12-12 | 2006-12-12 |  |  |  | 2006-12-12 | 0 | MERZ B | 1 | 1 | 5 | N/A | BILL M |  |  |  |  |  |  |  |  |
| 121221045M |  | Preliminary Design & Safety Review Complete (BOX SUP) | milestone | 0d | 2007-05-18 A | 2007-05-18 A | 121221040 | 100% | 2007-03-23 | 2007-03-23 |  |  |  | 2007-03-23 | 0 | MERZ B | 1 | 1 | 5 | N/A | BILL M |  |  |  |  |  |  |  |  |
| 121221070 |  | Write Preliminary PS Design Document (BOX SUP) |  | 40d | 2007-08-20 A | 2007-10-15 A | 121221065 | 100% |  |  | COMP SCIENT [34.8 h]; ELEC ENG [34.8 h]; ELEC DES [34.8 h] | 5,601.74 | 5,601.74 | 2007-07-31 | 5610.013254 | MERZ B | 1 | 1 |  | N/A | BILL M | 0 | 07-027 |  |  |  |  |  |  |
| 121221085 |  | Develop Dsgn & Specification for 1000 kW Box PS |  | 275d | 2007-10-01 A | 2008-11-06 A | 121221075M, 9-080M | 100% |  |  | ELEC ENG [80 h]; COMP SCIENT [40 h]; ELEC DES [20 h] | 8,210.67 | 8,210.67 |  | 8185 | MERZ B | 1 | 1 |  | N/A | BILL M | 0 |  |  |  |  |  |  |  |
| 121221090 |  | Develop Dsgn & Specification for 600 kW Box PS |  | 275d | 2007-10-01 A | 2008-11-06 A | 9-080M | 100% |  |  | ELEC DES [20 h]; ELEC ENG [80 h]; COMP SCIENT [40 h] | 8,210.67 | 8,210.67 |  | 8185 | MERZ B | 1 | 1 |  | N/A | BILL M | 0 |  |  |  |  |  |  |  |
| 121221095 |  | Develop Dsgn & Specification for Low Power (100/30 kW) Box PS |  | 275d | 2007-10-01 A | 2008-11-06 A | 9-080M | 100% |  |  | COMP SCIENT [40 h]; ELEC DES [20 h]; ELEC ENG [80 h] | 8,210.67 | 8,210.67 |  | 8185 | MERZ B | 1 | 1 |  | N/A | BILL M | 0 |  |  |  |  |  |  |  |
| 121221100 |  | Develop Design Spec for Dummy load |  | 280d | 2007-11-05 A | 2008-12-22 A | 9-080M FS+80d | 100% |  |  | ELEC ENG [80 h]; ELEC DES [80 h]; ELEC TECH [40 h] | 10,166.2 | 10,166.2 |  | 10100.4 | MERZ B | 1 | 1 |  | N/A | BILL M | 0 |  |  |  |  |  |  |  |
| 121221075M |  | Preliminary PS Design Document Complete (BOX SUP) | milestone | 0d | 2007-11-15 A | 2007-11-15 A | 121221070 | 100% |  |  |  |  |  | 2007-07-31 | 0 | MERZ B | 1 | 1 | 5 | N/A | BILL M |  |  |  |  |  |  |  |  |
| 121221105 |  | Develop Box PS Re-use Plans |  | 234d | 2008-02-19 A | 2009-01-27 A | 9-080M FS+80d | 100% |  |  | ELEC ENG [40 h] | 2,515.45 | 2,515.45 |  | 2489.6 | MERZ B | 1 | 1 |  | N/A | BILL M | 0 |  |  |  |  |  |  |  |
| 121221110 |  | Prepare Procurement Plan for Box PS Refurbishment |  | 234d | 2008-02-19 A | 2009-01-27 A | 121221105 | 100% |  |  | ELEC ENG [160 h] | 10,061.81 | 10,061.81 |  | 9958.4 | MERZ B | 1 | 1 |  | N/A | BILL M | 0 |  |  |  |  |  |  |  |
| 121221125 |  | Create Bill of Materials & Parts List for YA and Shunt PS |  | 259d | 2008-05-14 A | 2009-05-29 A | 121221120 | 100% |  |  | ELEC TECH [80 h]; ELEC ENG [40 h]; ELEC DES [40 h] | 7,533.62 | 7,533.62 |  | 7386 | MERZ B | 1 | 1 |  | H | BILL M | 0 |  |  |  |  |  |  |  |
| 121221120 |  | Develop Plan for YA and Shunt PS |  | 214d | 2008-05-15 A | 2009-03-27 A | 121221095, 121221085, 121221090 | 100% |  |  | ELEC ENG [80 h] | 5,066.98 | 5,066.98 |  | 4979.2 | MERZ B | 1 | 1 |  | H | BILL M | 0 |  | C |  |  |  |  |  |
| 121221140 |  | Update Cost & Labor Estimates (Box SUPPLIES) |  | 172d | 2008-07-14 A | 2009-03-25 A | 121221135 | 100% |  |  | ELEC ENG [40 h]; ELEC TECH [20 h] | 3,338.61 | 3,338.61 |  | 3268.2 | MERZ B | 1 | 1 |  | H | BILL M | 0 | 07-027 | C |  |  |  |  |  |
| 121221145 |  | Update Schedule (Box SUPPLIES) |  | 232d | 2008-07-16 A | 2009-06-22 A | 121221135 | 100% |  |  | ELEC TECH [20 h]; ELEC ENG [40 h] | 3,348.3 | 3,348.3 |  | 3268.2 | MERZ B | 1 | 1 |  | H | BILL M | 0 | 07-027 | C |  |  |  |  |  |
| 121221150 |  | Prep Final Specification & Prcrmnt Package (Box SUPPLIES)+ |  | 18d | 2008-12-18 A | 2009-01-21 A | 121221125 FS-25d, 121221140 FS-25d, 121221110 FS-25d, 121221145 FS-25d | 100% |  |  | ELEC ENG [160 h]; COMP SCIENT [40 h] | 12,665.2 | 12,665.2 |  | 12273.2 | MERZ B | 1 | 1 |  | H | BILL M | 0 | 07-027 |  |  |  |  |  |  |
| 121221135 |  | Pre-Constrctn Final Sys & Safty Review (Box SUPPLIES) |  | 30d | 2009-09-21 A | 2009-10-30 A | 121221100 | 100% |  |  | ELEC TECH [20 h]; ELEC ENG [160 h] | 11,338.33 | 11,338.33 |  | 10737 | MERZ B | 1 | 1 |  | H | BILL M | 0 |  | C |  |  |  |  |  |
| 121221155 |  | Re-Baseline Actuals Adjustment |  | 1d | 2013-08-30 A | 2013-08-30 A |  | 100% | 2013-09-03 | 2013-09-03 | PROCUREMENT>$50K 69 NO ESCALATION | 30,578.01 |  |  | 30578.01 |  |  |  |  |  |  |  |  |  | 0 | 30578.01 | 3057801 | 100 | ADJ |

| ID | WBS | Activity | Type | Duration | Start | Finish | Predecessors | Complete | Planned start | Planned finish | Resources | Cost | Actual cost | Planned FinishUDF | MONTHLY EV COST | RESP - Responsibility | STRT%COMP for CM EVM | FNSH%COMP for CM EVM | Milestone Level | EVMS Reporting Codes | CAM RESPONSIBLE | Calculated Remaining Total Cost | CR 09-012 | Remaining Material Cost Based on % Compl | Claimed Material Cost Based on % Complet | Initial Claimed Material Calc | Claimed Material Divider | CR 07-027 | CR 08-005 | WBS ASSIGNMENT | EXPNS ACT BRIDGING FY SPLIT | CR 09-001 | Profile change | ReBaseline Actuals Adjustment |
| --- | --- | --- | --- | --- | --- | --- | --- | --- | --- | --- | --- | --- | --- | --- | --- | --- | --- | --- | --- | --- | --- | --- | --- | --- | --- | --- | --- | --- | --- | --- | --- | --- | --- | --- |
|  | 2 | **1.2.1.2.2.2 SHUNTS - PED** |  |  |  |  |  |  |  |  |  |  |  |  |  |  |  |  |  |  |  |  |  |  |  |  |  |  |  |  |  |  |  |  |
|  | 3 | **1.2.1.2.2.3 TRIMS - PED** |  |  | 2006-11-01 | 2013-08-30 |  |  |  |  |  |  |  |  |  |  |  |  |  |  |  |  |  |  |  |  |  |  |  |  |  |  |  |  |
| 121223000M |  | Start Trim PED (TRIMS) | milestone | 0d | 2006-11-01 A | 2006-11-01 A | 9-070M | 100% | 2006-10-02 | 2006-10-02 |  |  |  | 2006-10-02 | 0 | MERZ B | 1 | 1 | 9 | N/A | BILL M |  |  |  |  |  |  |  |  |  |  |  |  |  |
| 121223005 |  | Update Trim PS Counts and System design- update TDR (TRIMS) |  | 102d | 2006-11-01 A | 2007-04-05 A | 121223000M | 100% |  |  | ELEC ENG [69.6 h] | 4,587.69 | 4,587.69 | 2007-01-10 | 4598.472 | MERZ B | 1 | 1 |  | N/A | BILL M | 0 | 09-012 |  |  |  |  |  |  |  |  |  |  |  |
| 121223010 |  | Procure utility chassis sample and Bulk PS sample (TRIMS) |  | 77d | 2006-12-15 A | 2007-04-12 A | 121223000M | 100% |  |  | PROCUREMENT<$50K 60 | 15,480 |  | 2007-01-02 | 15480 | MERZ B | 1 | 1 |  | N/A | BILL M | 0 |  | 0 | 15480 | 1548000 | 100 |  |  |  |  |  |  |  |
| 121223025 |  | Update Trim PS Cost estimate (TRIMS) |  | 58d | 2007-01-31 A | 2007-04-23 A | 121223010, 121223020, 121223005 | 100% |  |  | ELEC ENG [34.8 h] | 2,261.32 | 2,261.32 | 2007-03-29 | 2299.236 | MERZ B | 1 | 1 |  | N/A | BILL M | 0 | 09-012 |  |  |  |  |  |  |  |  |  |  |  |
| 121223020 |  | Install samples into Trim test stand and Test (TRIMS) |  | 130d | 2007-03-19 A | 2007-09-19 A | 121223015M | 100% |  |  | ELEC DES [69.6 h] | 3,076.55 | 3,076.55 | 2007-02-14 | 3130.608 | MERZ B | 1 | 1 |  | N/A | BILL M | 0 | 09-012 |  |  |  |  |  |  |  |  |  |  |  |
| 121223030 |  | Develop resource loaded schedule (TRIMS) |  | 21d | 2007-03-26 A | 2007-04-23 A | 121223025 | 100% |  |  | ELEC ENG [69.6 h] | 4,389.01 | 4,389.01 | 2007-05-24 | 4330.425 | MERZ B | 1 | 1 |  | N/A | BILL M | 0 | 09-012 |  |  |  |  |  |  |  |  |  |  |  |
| 121223015M |  | Receive sample hardware (TRIMS) | milestone | 0d | 2007-04-12 A | 2007-04-12 A | 121223010 | 100% | 2007-01-02 | 2007-01-02 |  |  |  | 2007-01-02 | 0 | MERZ B | 1 | 1 | 5 | N/A | BILL M |  |  |  |  |  |  |  |  |  |  |  |  |  |
| 121223030M |  | Start Trim FY08 PED (TRIMS) | milestone | 0d | 2007-10-01 A | 2007-10-01 A | 9-080M | 100% | 2007-11-01 | 2007-11-01 |  |  |  |  | 0 | MERZ B | 1 | 1 | 6 | N/A | BILL M |  |  |  |  |  |  |  |  |  |  |  |  |  |
| 121223032 |  | Proc Sample Commercial PS (TRIMS) |  | 111d | 2007-10-01 A | 2008-03-18 A | 9-080M, 121223030M | 100% |  |  | ELEC ENG [40 h]; PROCUREMENT<$50K 60 | 8,681 | 2,489.6 |  | 8681 | MERZ B | 1 | 1 |  | N/A | BILL M | 0 |  | 0 | 6191.4 | 619140 | 100 |  |  |  |  |  |  |  |
| 121223045 |  | Prep Trim Sys Database (TRIMS) |  | 106d | 2007-11-02 A | 2008-04-14 A | 121223040 | 100% |  |  | COMP SCIENT [160 h]; ELEC ENG [120 h] | 16,728 | 16,728 |  | 16728 | MERZ B | 1 | 1 |  | N/A | BILL M | 0 |  |  |  |  |  |  |  |  |  |  |  |  |
| 121223040 |  | Develop Specification for 20 amp trim (TRIMS) |  | 239d | 2008-01-14 A | 2008-12-22 A | 121223035 | 100% |  |  | ELEC ENG [120 h]; ELEC DES [40 h]; COMP SCIENT [40 h]; SUPPLIES & MATERIALS | 13,779.45 | 11,653.74 |  | 13691.314 | MERZ B | 1 | 1 |  | N/A | BILL M | 0 |  |  |  |  |  |  |  |  |  |  |  |  |
| 121223035 |  | Test Sample PS (TRIMS) |  | 7d | 2008-03-03 A | 2008-03-11 A | 121223032 | 100% |  |  | ELEC TECH [120 h]; ELEC ENG [40 h] | 7,161.2 | 7,161.2 |  | 7161.2 | MERZ B | 1 | 1 |  | N/A | BILL M | 0 |  |  |  |  |  |  |  |  |  |  |  |  |
| 121223060 |  | FY08 Prep Final Specification & Prcrmnt Package (TRIMS) |  | 318d | 2008-05-15 A | 2009-08-24 A | 121223050 FS-60d, 9-080M, 121223055 FS-43d | 100% |  |  | ELEC ENG [72 h] | 4,581.31 | 4,581.31 |  | 4481.28 | MERZ B | 1 | 1 |  | H | BILL M | 0 |  |  |  |  |  | 07-027 | 08-005 | 1.2.1.2.2.3 | EXP0809 | 09-001 |  |  |
| 121223055 |  | Develop Sys Drawings (TRIMS)++ |  | 248d | 2008-06-23 A | 2009-06-22 A | 121223045 FS-15d | 100% |  |  | ELEC DES [80 h] | 3,646.11 | 3,646.11 |  | 3564 | MERZ B | 1 | 1 |  | H | BILL M | 0 |  |  |  |  |  |  | 08-005 |  |  |  |  |  |
| 121223060a |  | FY09 Prep Final Specification & Prcrmnt Package (TRIMS) |  | 107d | 2009-03-25 A | 2009-08-24 A | 121223060 FS-250d | 100% |  |  | ELEC ENG [48 h] | 3,083.04 | 3,083.04 |  | 3083.04 | MERZ B | 1 | 1 |  | H | BILL M | 0 |  |  |  |  |  | 07-027 | 08-005 | 1.2.1.2.2.3 | EXP0809 | 09-001 |  |  |
| 121223050 |  | Pre-Constrctn Final Sys & Safty Review (TRIMS)++ |  | 30d | 2009-09-21 A | 2009-10-30 A | 121223045, 121223055 FS-27d | 100% |  |  | ELEC ENG [80 h]; COMP SCIENT [40 h] | 7,702.51 | 7,702.51 |  | 7294 | MERZ B | 1 | 1 |  | H | BILL M | 0 |  |  |  |  |  |  | 08-005 |  |  |  | C |  |
| 121223065 |  | Re-Baseline Actuals Adjustment |  | 1d | 2013-08-30 A | 2013-08-30 A |  | 100% | 2013-09-03 | 2013-09-03 | PROCUREMENT>$50K 69 NO ESCALATION | 8,131.73 |  |  | 8131.73 |  |  |  |  |  |  |  |  | 0 | 8131.73 | 813173 | 100 |  |  |  |  |  |  | ADJ |
|  | 4 | **1.2.1.2.2.4 INSTALLATION - PED** |  |  | 2006-11-01 | 2013-08-30 |  |  |  |  |  |  |  |  |  |  |  |  |  |  |  |  |  |  |  |  |  |  |  |  |  |  |  |  |
| 121224022 |  | Preliminary Installation Integration (INSTALL) |  | 245d | 2006-11-01 A | 2007-10-26 A | 9-070M FS+22d | 100% |  |  | ELEC ENG [69.6 h] | 4,401.91 | 4,401.91 | 2007-05-30 | 4515.996 | MERZ B | 1 | 1 |  | N/A | BILL M | 0 |  |  |  |  |  |  |  |  |  |  |  |  |
| 121224010 |  | Update Hall D Equipment Layout (INSTALL) |  | 157d | 2007-01-15 A | 2007-08-27 A | 121224000M | 100% | 2007-01-16 | 2007-08-27 | ELEC ENG [13.92 h] | 876.87 | 876.87 | 2007-04-04 | 908.6976 | MERZ B | 1 | 1 |  | N/A | BILL M | 0 |  |  |  |  |  |  |  |  |  |  |  |  |
| 121224020 |  | Develop Box PS Cable Installation requirements (INSTALL) |  | 167d | 2007-01-31 A | 2007-09-26 A | 121224010 | 100% |  |  | ELEC ENG [17.4 h]; ELEC DES [17.4 h] | 1,857.9 | 1,857.9 | 2007-05-02 | 1863.54 | MERZ B | 1 | 1 |  | N/A | BILL M | 0 |  |  |  |  |  |  |  |  |  |  |  |  |
| 121224005 |  | Update Trim PS Counts (INSTALL) |  | 23d | 2007-03-15 A | 2007-04-16 A | 121224000M | 100% |  |  | ELEC ENG [6.96 h] | 446.7 | 446.7 | 2007-03-28 | 459.8472 | MERZ B | 1 | 1 |  | N/A | BILL M | 0 |  |  |  |  |  |  |  |  |  |  |  |  |
| 121224015 |  | Develop Trim Installation requirements (INSTALL) |  | 154d | 2007-03-15 A | 2007-10-19 A | 121224010, 121224005 | 100% |  |  | ELEC ENG [17.4 h]; ELEC DES [17.4 h] | 1,842.69 | 1,842.69 | 2007-05-02 | 1863.54 | MERZ B | 1 | 1 |  | N/A | BILL M | 0 |  |  |  |  |  |  |  |  |  |  |  |  |
| 121224025 |  | Update cost estimate (INSTALL) |  | 21d | 2007-03-19 A | 2007-04-16 A | 121224015, 121224020 | 100% |  |  | ELEC ENG [34.8 h] | 2,227.23 | 2,227.23 | 2007-05-23 | 2161.776 | MERZ B | 1 | 1 |  | N/A | BILL M | 0 |  |  |  |  |  |  |  |  |  |  |  |  |
| 121224000M |  | Start Installation Planning (INSTALL) | milestone | 0d | 2007-05-01 A | 2007-05-01 A | 9-070M FS+108d | 100% | 2007-03-15 | 2007-03-15 |  |  |  | 2007-03-15 | 0 | MERZ B | 1 | 1 | 9 | N/A | BILL M |  |  |  |  |  |  |  |  |  |  |  |  |  |
| 121224030 |  | Create Installation Plan and schedule (INSTALL) |  | 4d | 2007-10-01 A | 2007-10-04 A | 121224025 | 100% |  |  | ELEC ENG [34.8 h] | 2,165.95 | 2,165.95 | 2007-06-14 | 2161.776 | MERZ B | 1 | 1 |  | N/A | BILL M | 0 |  |  |  |  |  | 07-027 |  |  |  |  |  |  |
| 121224035 |  | Dsgn & Assemble Proto Box PS Cable Interconnection Sys (Installtn) |  | 114d | 2007-10-01 A | 2008-03-21 A | 9-080M | 100% |  |  | PROCUREMENT<$50K 60; ELEC ENG [80 h]; ELEC DES [20 h]; ELEC TECH [20 h]; SKLLD TRADE [80 h] | 15,201 | 9,009.6 |  | 15201 | MERZ B | 1 | 1 |  | N/A | BILL M | 0 |  | 0 | 6191.4 | 619140 | 100 |  |  |  |  |  |  |  |
| 121224040 |  | Review/Revise Cable Lists- DC Pwr, Interlocks, Controls - Develop Installtn Database (Installtn) |  | 294d | 2007-10-01 A | 2008-12-05 A | 9-080M | 100% |  |  | ELEC ENG [60 h]; ELEC TECH [40 h]; COMP SCIENT [160 h]; SUPPLIES & MATERIALS | 16,749.01 | 14,623.3 |  | 16676.514 | MERZ B | 1 | 1 |  | N/A | BILL M | 0 |  |  |  |  |  |  |  |  |  |  |  |  |
| 121224045 |  | Dsgn Cable Tray Layout, Prep Installtn Drawings (Installtn) |  | 202d | 2008-01-14 A | 2008-10-28 A | 121224040 | 100% |  |  | ELEC ENG [40 h]; ELEC DES [60 h] | 5,178.98 | 5,178.98 |  | 5162.6 | MERZ B | 1 | 1 |  | N/A | BILL M | 0 |  |  |  |  |  |  |  |  |  |  |  |  |
| 121224050 |  | Develop Box Supply Shuffle-Rebuild-Install Plan & S/R Plan (Installtn) |  | 209d | 2008-03-03 A | 2009-01-02 A | 121224045 FS-20d | 100% |  |  | ELEC TECH [20 h]; ELEC ENG [80 h]; ELEC DES [20 h] | 6,709.83 | 6,709.83 |  | 6648.8 | MERZ B | 1 | 1 |  | N/A | BILL M | 0 |  |  |  |  |  |  |  |  |  |  |  |  |
| 121224055 |  | Prep/Dsgn Utility Installtn - LCW & AC Pwr (Installtn) |  | 227d | 2008-03-31 A | 2009-02-27 A | 121224050 FS-40d | 100% |  |  | ELEC DES [80 h]; ELEC ENG [20 h]; PROCUREMENT<$50K 60; ELEC TECH [40 h] | 11,778.58 | 6,453.98 |  | 11690.604 | MERZ B | 1 | 1 |  | N/A | BILL M | 0 |  | 0 | 5324.6 | 532460 | 100 |  |  |  |  |  |  |  |
| 121224060 |  | Prep Bill of Matrl's & Update Matrl's & Labor Cost Estimate (Installtn) |  | 239d | 2008-07-04 A | 2009-06-22 A | 121224055 FS-20d | 100% | 2008-07-07 | 2009-06-22 | COMP SCIENT [40 h]; SKLLD TRADE [40 h]; ELEC ENG [40 h]; ELEC TECH [40 h] | 7,721.04 | 7,721.04 |  | 7542 | MERZ B | 1 | 1 |  | H | BILL M | 0 |  |  |  |  |  |  |  |  |  |  |  |  |
| 121224065 |  | Perform Installtn Hazard Analysis & Revise Schedule (Installtn)++ |  | 191d | 2009-02-02 A | 2009-10-30 A | 121224060 FS-5d | 100% |  |  | ELEC ENG [80 h] | 5,157.2 | 5,157.2 |  | 4979.2 | MERZ B | 1 | 1 |  | H | BILL M | 0 |  |  |  |  |  |  |  |  |  |  |  |  |
| 121224999 |  | Pre-Constrctn Final Sys & Safty Review (Installtn)++ |  | 15d | 2009-10-12 A | 2009-10-30 A | 121224065, 121224035 | 100% |  |  |  |  |  |  | 0 | MERZ B | 1 | 1 |  | Z | BILL M |  |  |  |  |  |  |  |  |  |  |  | C |  |
| 121224070 |  | Re-Baseline Actuals Adjustment |  | 1d | 2013-08-30 A | 2013-08-30 A |  | 100% | 2013-09-03 | 2013-09-03 | PROCUREMENT>$50K 69 NO ESCALATION | 49,727.97 |  |  | 49727.97 |  |  |  |  |  |  |  |  | 0 | 49727.97 | 4972797 | 100 |  |  |  |  |  |  | ADJ |

| ID | WBS | Activity | Type | Duration | Start | Finish | Predecessors | Complete | Planned start | Planned finish | Resources | Cost | Actual cost | Planned FinishUDF | MONTHLY EV COST | RESP - Responsibility | STRT%COMP for CM EVM | FNSH%COMP for CM EVM | Milestone Level | EVMS Reporting Codes | CAM RESPONSIBLE | Calculated Remaining Total Cost | CR 09-012 | Claimed Material Divider | ReBaseline Actuals Adjustment | CR 07-010 | CR 07-027 | Profile change | Remaining Material Cost Based on % Compl | Claimed Material Cost Based on % Complet | Initial Claimed Material Calc |
| --- | --- | --- | --- | --- | --- | --- | --- | --- | --- | --- | --- | --- | --- | --- | --- | --- | --- | --- | --- | --- | --- | --- | --- | --- | --- | --- | --- | --- | --- | --- | --- |
|  | 3 | **1.2.1.3 CRYOGENICS** |  |  | 2006-10-02 | 2013-08-30 |  |  |  |  |  |  |  |  |  |  |  |  |  |  |  |  |  |  |  |  |  |  |  |  |  |
|  | 1 | **1.2.1.3.1 ACCELERATOR** |  |  | 2006-10-02 | 2013-08-30 |  |  |  |  |  |  |  |  |  |  |  |  |  |  |  |  |  |  |  |  |  |  |  |  |  |
| 12131010M |  | Preliminary Engineering Design & Safety Review Completed (ACCEL) | milestone | 0d | 2007-07-23 A | 2007-07-23 A | 12131.04010 | 100% | 2007-01-12 | 2007-01-12 |  |  |  | 2007-01-12 | 0 | ARENIUS D | 1 | 1 | 5 | N/A | DANA A |  |  |  |  |  |  |  |  |  |  |
|  | 01 | **1.2.1.3.1.01 CHL BUILDING LAYOUT & UTILITIES REQ** |  |  | 2006-10-02 | 2013-08-30 |  |  |  |  |  |  |  |  |  |  |  |  |  |  |  |  |  |  |  |  |  |  |  |  |  |
| 12131.01005 |  | Develop CHL Building Layout and Utility Schedule (CHL BLDG) |  | 58d | 2006-10-02 A | 2006-12-22 A | 9-070M | 100% |  |  | SR STAFF [104.4 h]; ELEC ENG [104.4 h] | 17,405.83 | 17,405.83 | 2006-10-20 | 17405.829 | ARENIUS D | 1 | 1 |  | N/A | DANA A | 0 | 09-012 |  |  |  |  |  |  |  |  |
| 12131.01010 |  | Re-Baseline Actuals Adjustment |  | 1d | 2013-08-30 A | 2013-08-30 A |  | 100% | 2013-09-03 | 2013-09-03 | PROCUREMENT>$50K 69 NO ESCALATION | -5,734.45 |  |  |  |  |  |  |  |  |  |  |  | 100 | ADJ |  |  |  |  |  |  |
|  | 02 | **1.2.1.3.1.02 CHL SYSTEM P&ID DEVELOPMENT** |  |  |  |  |  |  |  |  |  |  |  |  |  |  |  |  |  |  |  |  |  |  |  |  |  |  |  |  |  |
|  | 03 | **1.2.1.3.1.03 CHL WARM HELIUM COMPRESSORS** |  |  | 2006-12-07 | 2013-08-30 |  |  |  |  |  |  |  |  |  |  |  |  |  |  |  |  |  |  |  |  |  |  |  |  |  |
| 12131.03005 |  | Develop Warm Helium Compressor Piping Dsgn, Prelim |  | 68d | 2006-12-07 A | 2007-03-22 A | 9-070M | 100% |  |  | ELEC DES [52 h]; SUPPLIES & MATERIALS; TRAVEL; SR STAFF [20.8 h]; MECH ENG [104.4 h]; MECH DES [146.16 h]; ELEC ENG [89.09 h] | 25,720.58 | 23,245.58 | 2007-01-05 | 25720.59296 | ARENIUS D | 1 | 1 |  | N/A | DANA A | 0 | 09-012 |  |  | 07-010 |  |  |  |  |  |
| 12131.03010 |  | FY-07 Develop Warm Helium Compressor Piping Design Initial Phase Final Design (CHL WARM HEL COMPR) |  | 26d | 2007-08-03 A | 2007-09-10 A | 12131.06010, 12131.05010 FS-21d | 100% |  |  | ELEC ENG [22.4 h]; SUPPLIES & MATERIALS; TRAVEL; MECH ENG [111.6 h]; SR STAFF [118.4 h]; MECH DES [28.4 h] | 34,678.79 | 20,643.79 | 2007-06-26 | 35509.044 | ARENIUS D | 1 | 1 |  | N/A | DANA A | 0 | 09-012 |  |  | 07-010 | 07-027 | C |  |  |  |
| 12131.03012 |  | FY-08 Develop Wrm He Cmprssr Piping Dsgn, Initl Phase Final Dsgn |  | 36d | 2008-03-12 A | 2008-04-30 A | 12131.03010 FS+120d | 100% |  |  | ELEC ENG [200 h]; MECH ENG [1520 h]; MECH DES [800 h]; ELEC DES [120 h] | 145,774.8 | 145,774.8 |  | 150426.8 | ARENIUS D | 1 | 1 |  | H | DANA A | 0 |  |  |  |  | 07-027 |  |  |  |  |
| 12131.03015 |  | CHL Warm Helium Compressors++ |  | 134d | 2008-04-04 A | 2008-10-13 A | 9-080M, 12131.03012 | 100% |  |  | ELEC DES [120 h]; SR STAFF [280 h]; MECH ENG [600 h]; MECH DES [320 h]; ELEC ENG [160 h] | 94,108.14 | 94,108.14 |  | 96904.4 | ARENIUS D | 1 | 1 |  | N/A | DANA A | 0 |  |  |  |  |  |  |  |  |  |
| 12131.03020 |  | CHL Warm Helium Compressors Pre-Constrctn Dsgn Review+ |  | 31d | 2009-03-09 A | 2009-04-20 A | 12131.03015, 9-090M FS+100d | 100% |  |  |  |  |  |  | 0 | ARENIUS D | 1 | 1 |  | Z | DANA A |  |  |  |  |  | 07-027 |  |  |  |  |
| 12131.03025 |  | Re-Baseline Actuals Adjustment |  | 1d | 2013-08-30 A | 2013-08-30 A |  | 100% | 2013-09-03 | 2013-09-03 | PROCUREMENT>$50K 69 NO ESCALATION | -152,043.6 |  |  |  |  |  |  |  |  |  |  |  | 100 | ADJ |  |  |  |  |  |  |
|  | 04 | **1.2.1.3.1.04 CHL COLD BOXES** |  |  | 2006-12-07 | 2013-08-30 |  |  |  |  |  |  |  |  |  |  |  |  |  |  |  |  |  |  |  |  |  |  |  |  |  |
| 12131.04005 |  | Develop CHL Cold Box Field Piping Design Preliminary (CHL COLD BOX) |  | 64d | 2006-12-07 A | 2007-03-16 A | 9-070M | 100% |  |  | MECH ENG [151.73 h]; ELEC DES [36.19 h]; SUPPLIES & MATERIALS; TRAVEL; SR STAFF [20.8 h]; MECH DES [141.29 h]; ELEC ENG [41.76 h] | 24,126.59 | 22,114.59 | 2007-01-05 | 24126.58968 | ARENIUS D | 1 | 1 |  | N/A | DANA A | 0 | 09-012 |  |  | 07-010 |  |  |  |  |  |
| 12131.04010 |  | Conduct Prelimin Eng Design & Safety Review for WBS 1.2.1.3.1 Elements (CHL COLD BOX) |  | 42d | 2007-03-16 A | 2007-05-14 A | 12131.11005, 12131.10005, 12131.06005, 12131.04005, 12131.03005, 12131.07005, 12131.01005, 12131.05005 | 100% |  |  | MECH ENG [104.4 h]; SR STAFF [104.4 h]; MECH DES [172.4 h]; ELEC ENG [69.6 h]; ELEC DES [32 h] | 30,378.3 | 30,378.3 | 2007-01-12 | 30636.189 | ARENIUS D | 1 | 1 |  | N/A | DANA A | 0 | 09-012 |  |  | 07-010 |  |  |  |  |  |
| 12131.04015 |  | FY-07 Develop CHL Cold Box Field Piping Design Initial Phase Final Design (CHL COLD BOX) |  | 111d | 2007-03-28 A | 2007-08-31 A | 12131010M | 100% |  |  | ELEC ENG [76.8 h]; TRAVEL; SUPPLIES & MATERIALS; MECH ENG [57.6 h]; SR STAFF [118.4 h] | 31,383.01 | 19,975.01 | 2007-05-15 | 31848.562165 | ARENIUS D | 1 | 1 |  | N/A | DANA A | 0 | 09-012 |  |  | 07-010 |  |  |  |  |  |
| 12131.04017 |  | FY-08 Develop CHL Cold Box Field Piping Dsgn, Final Phase Final Dsgn |  | 63d | 2007-10-01 A | 2008-01-08 A | 9-080M, 12131.04015 | 100% |  |  | ELEC DES [120 h]; MECH DES [800 h]; MECH ENG [800 h]; ELEC ENG [160 h] | 98,760.4 | 98,760.4 |  | 98760.4 | ARENIUS D | 1 | 1 |  | N/A | DANA A | 0 |  |  |  |  |  |  |  |  |  |
| 12131.04020 |  | P-1 CHL Cold Box, Dsgn Installtn+ |  | 92d | 2008-01-09 A | 2008-05-19 A | 9-080M, 12131.04017 | 100% |  |  | SR STAFF [120 h]; MECH ENG [480 h]; MECH DES [360 h]; ELEC ENG [80 h]; SUPPLIES & MATERIALS | 64,081.39 | 61,914.4 |  | 64081.39 | ARENIUS D | 1 | 1 |  | N/A | DANA A | 0 |  |  |  |  | 07-027 |  |  |  |  |
| 12131.04025 |  | P-2 CHL Cold Box, Dsgn Installtn+ |  | 188d | 2009-01-05 A | 2009-09-30 A | 1331.02000 FS-188d | 100% |  |  | SR STAFF [160 h]; MECH ENG [480 h]; MECH DES [400 h]; ELEC ENG [80 h]; SUPPLIES & MATERIALS | 72,025.66 | 69,757.6 |  | 72025.661509 | ARENIUS D | 1 | 1 |  | H | DANA A | 0 |  |  |  |  | 07-027 |  |  |  |  |
| 12131.04030 |  | Re-Baseline Actuals Adjustment |  | 1d | 2013-08-30 A | 2013-08-30 A |  | 100% | 2013-09-03 | 2013-09-03 | PROCUREMENT>$50K 69 NO ESCALATION | 64,773.06 |  |  | 64773.06 |  |  |  |  |  |  |  |  | 100 | ADJ |  |  |  | 0 | 64773.06 | 6477306 |
|  | 05 | **1.2.1.3.1.05 CHL OIL REMOVAL SYSTEMS** |  |  | 2006-12-07 | 2013-08-30 |  |  |  |  |  |  |  |  |  |  |  |  |  |  |  |  |  |  |  |  |  |  |  |  |  |
| 12131.05005 |  | Develop Oil Removal Equipment Fabricaton Drawings Preliminary (CHL OIL REM SYS) |  | 51d | 2006-12-07 A | 2007-02-27 A | 9-070M | 100% |  |  | ELEC DES [10.44 h]; MECH ENG [15.31 h]; MECH DES [31.32 h]; ELEC ENG [15.31 h] | 3,815.34 | 3,815.34 | 2007-01-05 | 3815.33976 | ARENIUS D | 1 | 1 |  | N/A | DANA A | 0 |  |  |  |  |  |  |  |  |  |
| 12131.05010 |  | Develop Oil Removal Equipment Fabricaton Drawings Initial Phase Final Design (CHL OIL REM SYS) |  | 52d | 2007-06-11 A | 2007-08-22 A | 12131.06010 FS-21d | 100% |  |  | ELEC DES [59.16 h]; ELEC ENG [89.09 h]; MECH DES [177.48 h]; MECH ENG [89.09 h] | 20,836.22 | 20,836.22 | 2007-05-16 | 21576.263486 | ARENIUS D | 1 | 1 |  | N/A | DANA A | 0 |  |  |  |  | 07-027 |  |  |  |  |
| 12131.05020 |  | Re-Baseline Actuals Adjustment |  | 1d | 2013-08-30 A | 2013-08-30 A |  | 100% | 2013-09-03 | 2013-09-03 | PROCUREMENT>$50K 69 NO ESCALATION | 29,510.61 |  |  | 29510.61 |  |  |  |  |  |  |  |  | 100 | ADJ |  |  |  | 0 | 29510.61 | 2951061 |

Notes:
- 12131.03015: Entry Criteria: Ext Pred: 1.3.3.1.1
- 12131.03020: Entry Criteria: Ext Pred: 1.3.3.1.1
- 12131.04020: Entry Criteria: Ext Pred: / 1.3.3.1.2
- 12131.04025: Entry Criteria: Ext Pred: / 1.3.3.1.2

| ID | WBS | Activity | Duration | Start | Finish | Predecessors | Complete | Planned start | Planned finish | Resources | Cost | Actual cost | Planned FinishUDF | Calculated Remaining Total Cost | MONTHLY EV COST | RESP - Responsibility | STRT%COMP for CM EVM | FNSH%COMP for CM EVM | EVMS Reporting Codes | CAM RESPONSIBLE | Remaining Material Cost Based on % Compl | Claimed Material Cost Based on % Complet | Initial Claimed Material Calc | Claimed Material Divider | ReBaseline Actuals Adjustment | CR 07-010 | CR 07-027 | ACT BRIDGING FY SPLIT | CR 08-016 | WBS ASSIGNMENT | EXPNS ACT BRIDGING FY SPLIT | CR 09-001 | CR 09-012 | Profile change |
| --- | --- | --- | --- | --- | --- | --- | --- | --- | --- | --- | --- | --- | --- | --- | --- | --- | --- | --- | --- | --- | --- | --- | --- | --- | --- | --- | --- | --- | --- | --- | --- | --- | --- | --- |
|  | 06 | **1.2.1.3.1.06 CHL GAS MANAGEMENT RACK** |  | 2006-12-07 | 2013-08-30 |  |  |  |  |  |  |  |  |  |  |  |  |  |  |  |  |  |  |  |  |  |  |  |  |  |  |  |  |  |
| 12131.06005 |  | Develop Gas Management Rack Assembly and Fabrication Drawings Preliminary (CHL GAS MNGMT RACK) | 49d | 2006-12-07 A | 2007-02-23 A | 9-070M | 100% |  |  | ELEC DES [16.01 h]; ELEC ENG [16.01 h]; MECH DES [20.88 h] | 2,703.3 | 2,703.3 | 2007-01-05 | 0 | 2703.2988 | ARENIUS D | 1 | 1 | N/A | DANA A |  |  |  |  |  |  |  |  |  |  |  |  |  |  |
| 12131.06010 |  | Develop Gas Management Rack Assembly and Fabrication Drawings Initial Phase Final Design (CHL GAS MNGMT RACK) | 97d | 2007-03-14 A | 2007-07-30 A | 12131010M FS+40d | 100% |  |  | ELEC ENG [88.39 h]; ELEC DES [88.39 h]; MECH DES [118.32 h] | 14,569.05 | 14,569.05 | 2007-04-20 | 0 | 14835.981985 | ARENIUS D | 1 | 1 | N/A | DANA A |  |  |  |  |  |  |  |  |  |  |  |  |  |  |
| 12131.06015 |  | Re-Baseline Actuals Adjustment | 1d | 2013-08-30 A | 2013-08-30 A |  | 100% | 2013-09-03 | 2013-09-03 | PROCUREMENT>$50K 69 NO ESCALATION | 12,173.85 |  |  |  | 12173.85 |  |  |  |  |  | 0 | 12173.85 | 1217385 | 100 | ADJ |  |  |  |  |  |  |  |  |  |
|  | 07 | **1.2.1.3.1.07 CHL SYSTEM INSTRUMENTATION & CONTROLS** |  | 2007-01-04 | 2013-08-30 |  |  |  |  |  |  |  |  |  |  |  |  |  |  |  |  |  |  |  |  |  |  |  |  |  |  |  |  |  |
| 12131.07005 |  | Develop CHL Instrumentation and Controls Assembly Design Preliminary (CHL SYS INSTR & CNTRLS) | 50d | 2007-01-04 A | 2007-03-16 A | 9-070M | 100% |  |  | SUPPLIES & MATERIALS; ELEC ENG [350.09 h]; ELEC DES [183.05 h]; PROCUREMENT<$50K 60 | 34,158.81 | 31,363.81 | 2007-01-05 | 0 | 34158.8132 | ARENIUS D | 1 | 1 | N/A | DANA A | 0 | 1395 | 139500 | 100 |  | 07-010 |  |  |  |  |  |  |  |  |
| 12131.07010 |  | FY-07 Develop CHL Instrumentation and Controls Assembly Design Initial Phase Final Design (CHL SYS INSTR & CNTRLS) | 140d | 2007-03-09 A | 2007-09-25 A | 12131010M | 100% |  |  | ELEC ENG [181.6 h]; SUPPLIES & MATERIALS; ELEC DES [114.8 h]; PROCUREMENT<$50K 60 | 32,082.55 | 16,297.55 | 2007-09-28 | 0 | 32253.787397 | ARENIUS D | 1 | 1 | N/A | DANA A | 0 | 7895 | 789500 | 100 |  | 07-010 |  |  |  |  |  |  |  |  |
| 12131.07012 |  | FY-08 Develop CHL Inst & Controls Assy Dsgn, Initl Phase Final Dsgn | 149d | 2007-10-01 A | 2008-05-09 A | 9-080M, 12131.07010 | 100% |  |  | ELEC DES [360 h]; ELEC ENG [720 h] | 60,850.8 | 60,850.8 |  | 0 | 60850.8 | ARENIUS D | 1 | 1 | N/A | DANA A |  |  |  |  |  |  | 07-027 |  |  |  |  |  |  |  |
| 12131.07015 |  | PROC Engineer CHL Sys Instrmenttn & Controls+ | 347d | 2008-05-12 A | 2009-09-30 A | 12131.07012 | 100% |  |  | PROCUREMENT<$50K 60 NO ESCALATION FY09 | 7,450.32 |  |  | 0 | 7450.318 | ARENIUS D | 1 | 1 | N/A | DANA A | 0 | 7450.32 | 745032 | 100 |  |  | 07-027 | FY08-09 | 08-016 | 1.2.1.3.1.07 | EXP0809 | 09-001 | 09-012 |  |
| 12131.07015a |  | FY08 LAB/EXP Engineer CHL Sys Instrmenttn & Controls+ | 88d | 2008-05-12 A | 2008-09-15 A | 12131.07012 | 100% |  |  | ELEC ENG [156.8 h]; ELEC DES [84.43 h]; SUPPLIES & MATERIALS | 15,770.26 | 13,520.59 |  | 0 | 15770.2585 | ARENIUS D | 1 | 1 | N/A | DANA A |  |  |  |  |  |  | 07-027 | FY08-09 | 08-016 | 1.2.1.3.1.07 | EXP0809 | 09-001 |  |  |
| 12131.07015b |  | FY09 LAB/EXP Engineer CHL Sys Instrmenttn & Controls+ | 238d | 2008-09-16 A | 2009-08-31 A | 12131.07015a | 100% |  |  | ELEC DES [195.57 h]; ELEC ENG [363.2 h]; SUPPLIES & MATERIALS | 37,651.51 | 32,274.31 |  | 0 | 37697.8446 | ARENIUS D | 1 | 1 | N/A | DANA A |  |  |  |  |  |  | 07-027 | FY08-09 | 08-016 | 1.2.1.3.1.07 | EXP0809 | 09-001 |  |  |
| 12131.07020 |  | Re-Baseline Actuals Adjustment | 1d | 2013-08-30 A | 2013-08-30 A |  | 100% | 2013-09-03 | 2013-09-03 | PROCUREMENT>$50K 69 NO ESCALATION | 164,930.64 |  |  |  | 164930.64 |  |  |  |  |  | 0 | 164930.64 | 16493064 | 100 | ADJ |  |  |  |  |  |  |  |  |  |
|  | 08 | **1.2.1.3.1.08 CHL INSTRUMENT AIR SYSTEM** |  | 2009-01-19 | 2013-08-30 |  |  |  |  |  |  |  |  |  |  |  |  |  |  |  |  |  |  |  |  |  |  |  |  |  |  |  |  |  |
| 12131.08000 |  | CHL Instrument Air Sys Engrng+ | 92d | 2009-01-19 A | 2009-05-29 A | 9-090M FS+125d | 100% | 2009-01-20 | 2009-05-29 | MECH ENG [560 h]; MECH DES [560 h]; ELEC DES [120 h] | 65,801.6 | 65,801.6 |  | 0 | 65801.6 | ARENIUS D | 1 | 1 | H | DANA A |  |  |  |  |  |  | 07-027 |  |  |  |  |  |  |  |
| 12131.08010 |  | Re-Baseline Actuals Adjustment | 1d | 2013-08-30 A | 2013-08-30 A |  | 100% | 2013-09-03 | 2013-09-03 | PROCUREMENT>$50K 69 NO ESCALATION | -64,644.64 |  |  |  |  |  |  |  |  |  |  |  |  | 100 | ADJ |  |  |  |  |  |  |  |  |  |
|  | 09 | **1.2.1.3.1.09 MOTOR CONTROL CENTERS** |  | 2008-12-16 | 2013-08-30 |  |  |  |  |  |  |  |  |  |  |  |  |  |  |  |  |  |  |  |  |  |  |  |  |  |  |  |  |  |
| 12131.09000 |  | Motor Control Center Specification Development+ | 110d | 2008-12-16 A | 2009-05-29 A | 9-090M FS+85d | 100% |  |  | ELEC DES [80 h]; ELEC ENG [120 h]; MECH DES [40 h] | 13,139.6 | 13,139.6 |  | 0 | 13139.6 | ARENIUS D | 1 | 1 | H | DANA A |  |  |  |  |  |  | 07-027 |  |  |  |  |  |  |  |
| 12131.09005 |  | Re-Baseline Actuals Adjustment | 1d | 2013-08-30 A | 2013-08-30 A |  | 100% | 2013-09-03 | 2013-09-03 | PROCUREMENT>$50K 69 NO ESCALATION | -4,580.24 |  |  |  |  |  |  |  |  |  |  |  |  | 100 | ADJ |  |  |  |  |  |  |  |  |  |
|  | 10 | **1.2.1.3.1.10 CHL INSTALLATION DESIGN** |  | 2007-01-04 | 2013-08-30 |  |  |  |  |  |  |  |  |  |  |  |  |  |  |  |  |  |  |  |  |  |  |  |  |  |  |  |  |  |
| 12131.10005 |  | Develop Utility Field Piping Installation Design Preliminary (CHL INSTAL DES) | 51d | 2007-01-04 A | 2007-03-19 A | 9-070M | 100% |  |  | MECH DES [626.4 h]; MECH ENG [278.4 h] | 44,962.29 | 44,962.29 | 2006-12-19 | 0 | 44962.296 | ARENIUS D | 1 | 1 | N/A | DANA A |  |  |  |  |  |  |  |  |  |  |  |  |  |  |
| 12131.10010 |  | Engineer & Dsgn CHL Installtn+ | 216d | 2007-09-10 A | 2008-07-25 A | 9-080M | 100% | 2007-09-10 | 2008-07-24 | MECH DES [720 h]; SUPPLIES & MATERIALS; MECH ENG [320 h]; SR STAFF [240 h]; ELEC ENG [240 h]; ELEC DES [200 h] | 104,317.52 | 97,930.06 |  | 0 | 104527.861 | ARENIUS D | 1 | 1 | N/A | DANA A |  |  |  |  |  |  |  |  |  |  |  |  |  | C |
| 12131.10015 |  | Re-Baseline Actuals Adjustment | 1d | 2013-08-30 A | 2013-08-30 A |  | 100% | 2013-09-03 | 2013-09-03 | PROCUREMENT>$50K 69 NO ESCALATION | -99,346.46 |  |  |  |  |  |  |  |  |  |  |  |  | 100 | ADJ |  |  |  |  |  |  |  |  |  |
|  | 11 | **1.2.1.3.1.11 CHL COMMISSIONING PLANNING** |  | 2006-10-02 | 2013-08-30 |  |  |  |  |  |  |  |  |  |  |  |  |  |  |  |  |  |  |  |  |  |  |  |  |  |  |  |  |  |
| 12131.11005 |  | Develop CHL Commissioning Design and Plan Preliminary (CHL COMMIS) | 67d | 2006-10-02 A | 2007-01-12 A | 9-070M | 100% |  |  | MECH ENG [348 h]; MECH TECH [522 h]; ELEC TECH [174 h]; ELEC ENG [174 h] | 60,960.9 | 60,960.9 | 2006-11-17 | 0 | 60960.9 | ARENIUS D | 1 | 1 | N/A | DANA A |  |  |  |  |  |  |  |  |  |  |  |  |  |  |
| 12131.11010 |  | Develop CHL Cmmssng Plan++ | 41d | 2008-01-03 A | 2008-03-03 A | 9-080M FS+60d | 100% |  |  | MECH ENG [280 h]; ELEC ENG [160 h] | 27,273.6 | 27,273.6 |  | 0 | 27273.6 | ARENIUS D | 1 | 1 | N/A | DANA A |  |  |  |  |  |  | 07-027 |  |  |  |  |  |  | C |
| 12131.11015 |  | Re-Baseline Actuals Adjustment | 1d | 2013-08-30 A | 2013-08-30 A |  | 100% | 2013-09-03 | 2013-09-03 | PROCUREMENT>$50K 69 NO ESCALATION | -52,272.73 |  |  |  |  |  |  |  |  |  |  |  |  | 100 | ADJ |  |  |  |  |  |  |  |  |  |

Notes:
- 12131.10010: Entry Criteria: Ext Pred: 1.2.1.3.1.5; / 1.2.1.3.1.6; 1.2.1.3.1.1
- 12131.11010: Entry Criteria: Ext Pred: 1.2.1.3.1.2 system / P&ID which is / complete

| ID | WBS | Activity | Type | Duration | Start | Finish | Predecessors | Complete | Planned start | Planned finish | Resources | Cost | Actual cost | Calculated Remaining Total Cost | MONTHLY EV COST | RESP - Responsibility | STRT%COMP for CM EVM | FNSH%COMP for CM EVM | CR 07-027 | EVMS Reporting Codes | CAM RESPONSIBLE | Remaining Material Cost Based on % Compl | Claimed Material Cost Based on % Complet | Initial Claimed Material Calc | Claimed Material Divider | ReBaseline Actuals Adjustment | Planned FinishUDF | LOE Divider | LOE Multiplier | Milestone Level | CR 09-005 | CR 08-058 | WBS ASSIGNMENT | EXPNS ACT BRIDGING FY SPLIT | CR 09-001 | Activities with Steps |
| --- | --- | --- | --- | --- | --- | --- | --- | --- | --- | --- | --- | --- | --- | --- | --- | --- | --- | --- | --- | --- | --- | --- | --- | --- | --- | --- | --- | --- | --- | --- | --- | --- | --- | --- | --- | --- |
|  | 12 | **1.2.1.3.1.12 LINAC TRANSFER LINE** |  |  |  |  |  |  |  |  |  |  |  |  |  |  |  |  |  |  |  |  |  |  |  |  |  |  |  |  |  |  |  |  |  |  |
|  | 2 | **1.2.1.3.2 HALL D** |  |  | 2008-01-28 | 2013-08-30 |  |  |  |  |  |  |  |  |  |  |  |  |  |  |  |  |  |  |  |  |  |  |  |  |  |  |  |  |  |  |
|  | 1 | **1.2.1.3.2.1 CHL-HALL D TRANSFER LINE** |  |  |  |  |  |  |  |  |  |  |  |  |  |  |  |  |  |  |  |  |  |  |  |  |  |  |  |  |  |  |  |  |  |  |
|  | 2 | **1.2.1.3.2.2 HALL D COLD BOX** |  |  | 2009-02-11 | 2013-08-30 |  |  |  |  |  |  |  |  |  |  |  |  |  |  |  |  |  |  |  |  |  |  |  |  |  |  |  |  |  |  |
| 121322000 |  | Evaluate H-D Refrigerator Cold Box+ |  | 82d | 2009-02-11 A | 2009-06-08 A | 9-090M FS+125d | 100% |  |  | ELEC ENG [40 h]; MECH ENG [120 h] | 10,226.4 | 10,226.4 | 0 | 10226.4 | ARENIUS D | 1 | 1 | 07-027 | H | DANA A |  |  |  |  |  |  |  |  |  |  |  |  |  |  |  |
| 121322005 |  | Re-Baseline Actuals Adjustment |  | 1d | 2013-08-30 A | 2013-08-30 A |  | 100% | 2013-09-03 | 2013-09-03 | PROCUREMENT>$50K 69 NO ESCALATION | 15,582.69 |  |  | 15582.69 |  |  |  |  |  |  | 0 | 15582.69 | 1558269 | 100 | ADJ |  |  |  |  |  |  |  |  |  |  |
|  | 3 | **1.2.1.3.2.3 HALL D DISTRIBUTION SYSTEM** |  |  | 2009-01-09 | 2013-08-30 |  |  |  |  |  |  |  |  |  |  |  |  |  |  |  |  |  |  |  |  |  |  |  |  |  |  |  |  |  |  |
| 121323000 |  | Dsgn H-D Refrigerator Interconnecting Piping+ |  | 98d | 2009-01-09 A | 2009-05-29 A | 9-090M FS+65d | 100% |  |  | MECH ENG [240 h]; MECH DES [480 h] | 36,357.6 | 36,357.6 | 0 | 36357.6 | ARENIUS D | 1 | 1 | 07-027 | H | DANA A |  |  |  |  |  |  |  |  |  |  |  |  |  |  |  |
| 121323005 |  | Re-Baseline Actuals Adjustment |  | 1d | 2013-08-30 A | 2013-08-30 A |  | 100% | 2013-09-03 | 2013-09-03 | PROCUREMENT>$50K 69 NO ESCALATION | -36,357.61 |  |  |  |  |  |  |  |  |  |  |  |  | 100 | ADJ |  |  |  |  |  |  |  |  |  |  |
|  | 4 | **1.2.1.3.2.4 INSTRUMENTATION & CONTROLS** |  |  | 2008-01-28 | 2013-08-30 |  |  |  |  |  |  |  |  |  |  |  |  |  |  |  |  |  |  |  |  |  |  |  |  |  |  |  |  |  |  |
| 121324000 |  | Dsgn H-D Refrgerator Controls+ |  | 272d | 2008-01-28 A | 2009-03-02 A | 121323000 FS-90d | 100% |  |  | ELEC ENG [360 h]; ELEC DES [160 h] | 29,878.43 | 29,878.43 | 0 | 30479.6 | ARENIUS D | 1 | 1 | 07-027 | N/A | DANA A |  |  |  |  |  |  |  |  |  |  |  |  |  |  |  |
| 121324005 |  | Re-Baseline Actuals Adjustment |  | 1d | 2013-08-30 A | 2013-08-30 A |  | 100% | 2013-09-03 | 2013-09-03 | PROCUREMENT>$50K 69 NO ESCALATION | 436.04 |  |  | 436.04 |  |  |  |  |  |  | 0 | 436.04 | 43604 | 100 | ADJ |  |  |  |  |  |  |  |  |  |  |
|  | 5 | **1.2.1.3.2.5 U-TUBES** |  |  | 2009-01-13 | 2013-08-30 |  |  |  |  |  |  |  |  |  |  |  |  |  |  |  |  |  |  |  |  |  |  |  |  |  |  |  |  |  |  |
| 121325000 |  | Dsgn H-D Refrigerator U-Tubes+ |  | 96d | 2009-01-13 A | 2009-05-29 A | 9-090M FS+125d | 100% |  |  | MECH ENG [80 h]; MECH DES [80 h] | 8,612 | 8,612 | 0 | 8612 | ARENIUS D | 1 | 1 | 07-027 | H | DANA A |  |  |  |  |  |  |  |  |  |  |  |  |  |  |  |
| 121325005 |  | Re-Baseline Actuals Adjustment |  | 1d | 2013-08-30 A | 2013-08-30 A |  | 100% | 2013-09-03 | 2013-09-03 | PROCUREMENT>$50K 69 NO ESCALATION | -8,612.02 |  |  |  |  |  |  |  |  |  |  |  |  | 100 | ADJ |  |  |  |  |  |  |  |  |  |  |
|  | 6 | **1.2.1.3.2.6 FIELD INSTALLATION** |  |  |  |  |  |  |  |  |  |  |  |  |  |  |  |  |  |  |  |  |  |  |  |  |  |  |  |  |  |  |  |  |  |  |
|  | 7 | **1.2.1.3.2.7 COMMISSIONING** |  |  |  |  |  |  |  |  |  |  |  |  |  |  |  |  |  |  |  |  |  |  |  |  |  |  |  |  |  |  |  |  |  |  |
|  | 4 | **1.2.1.4 BEAM TRANSPORT** |  |  | 2006-10-02 | 2013-08-30 |  |  |  |  |  |  |  |  |  |  |  |  |  |  |  |  |  |  |  |  |  |  |  |  |  |  |  |  |  |  |
|  | 1 | **1.2.1.4.1 SPREADERS & RECOMBINERS** |  |  | 2006-10-02 | 2013-08-30 |  |  |  |  |  |  |  |  |  |  |  |  |  |  |  |  |  |  |  |  |  |  |  |  |  |  |  |  |  |  |
|  | 1 | **1.2.1.4.1.1 DIPOLES** |  |  | 2006-10-02 | 2013-08-30 |  |  |  |  |  |  |  |  |  |  |  |  |  |  |  |  |  |  |  |  |  |  |  |  |  |  |  |  |  |  |
| 121411007LOE |  | FY07 Management of S/R PED Effort (DIPOLES) |  | 247d | 2006-10-02 A | 2007-09-28 A | 9-070M | 100% |  |  | SCIENTIST [139.2 h]; MECH TECH [104.4 h]; MECH ENG [452.4 h]; SUPPLIES & MATERIALS | 61,290.85 | 40,650.85 | 0 | 61290.838424 | WINES R | 1 | 1 |  | N/A | MIKE B |  |  |  |  |  | 2007-09-28 | 100 | 100 |  |  |  |  |  |  |  |
| 121411025 |  | Develop Preliminary design of S/R Dipoles and Septa (DIPOLES) |  | 160d | 2006-10-02 A | 2007-05-25 A | 9-070M | 100% |  |  | MECH ENG [417.6 h]; MECH DES [208.8 h] | 35,044.99 | 35,044.99 | 0 | 35047.08 | WINES R | 1 | 1 |  | N/A | MIKE B |  |  |  |  |  | 2007-03-16 |  |  |  |  |  |  |  |  |  |
| 121411015 |  | Beam Transport Physics Design & Safety Review (DIPOLES) |  | 29d | 2006-12-06 A | 2007-01-24 A | 9-070M FS+45d | 100% |  |  | SCIENTIST [69.6 h] | 4,467.62 | 4,467.62 | 0 | 4467.624 | WINES R | 1 | 1 |  | N/A | MIKE B |  |  |  |  |  | 2007-01-25 |  |  |  |  |  |  |  |  |  |
| 121411015M |  | Beam Transport Physics Design & Safety Review Completed (DIPOLES) | milestone | 0d | 2007-01-24 A | 2007-01-24 A | 121411015 | 100% | 2007-01-25 | 2007-01-25 |  |  |  |  | 0 | WINES R | 1 | 1 |  | N/A | MIKE B |  |  |  |  |  | 2007-01-25 |  |  | 5 |  |  |  |  |  |  |
| 121411055 |  | Develop Detailed Design of New AG and 2m AH Replacements (DIPOLES) |  | 133d | 2007-02-12 A | 2007-08-20 A | 121411030M | 100% |  |  | MECH DES [382.8 h]; MECH ENG [139.2 h] | 25,089.49 | 25,089.49 | 0 | 24976.442391 | WINES R | 1 | 1 |  | N/A | MIKE B |  |  |  |  |  | 2007-08-21 |  |  |  |  |  |  |  |  |  |
| 121411020 |  | Installation Cost Schedule and Safety Review (DIPOLES) |  | 48d | 2007-03-14 A | 2007-05-18 A | 9-070M FS+147d | 100% |  |  | MECH ENG [69.6 h] | 4,312.71 | 4,312.71 | 0 | 4317.984 | WINES R | 1 | 1 |  | N/A | MIKE B |  |  |  |  |  | 2007-06-06 |  |  |  |  |  |  |  |  |  |
| 121411030 |  | Preliminary Design & Safety Review of S/R Dipoles and Septa (DIPOLES) |  | 35d | 2007-04-09 A | 2007-05-25 A | 121411025 FS-20d | 100% |  |  | MECH DES [35.6 h]; MECH ENG [35.6 h] | 3,765.41 | 3,765.41 | 0 | 3776.804 | WINES R | 1 | 1 |  | N/A | MIKE B |  |  |  |  |  | 2007-03-16 |  |  |  |  |  |  |  |  |  |
| 121411020M |  | Installation Cost Schedule and Safety Review Complete (DIPOLES) | milestone | 0d | 2007-05-18 A | 2007-05-18 A | 121411020 | 100% | 2007-06-06 | 2007-06-06 |  |  |  |  | 0 | WINES R | 1 | 1 |  | N/A | MIKE B |  |  |  |  |  | 2007-06-06 |  |  | 5 |  |  |  |  |  |  |
| 121411035 |  | FY07 Develop Detailed Design of West curved dipoles (DIPOLES) |  | 91d | 2007-05-21 A | 2007-09-27 A | 121411030M | 100% |  |  | MECH ENG [194.6 h]; MECH DES [340.55 h] | 26,091.97 | 26,091.97 | 0 | 26386.841098 | WINES R | 1 | 1 |  | N/A | MIKE B |  |  |  |  |  | 2007-09-28 |  |  |  |  |  |  |  |  |  |
| 121411045 |  | FY07 Develop Detailed Design of New 3m Septa (DIPOLES) |  | 114d | 2007-05-21 A | 2007-10-30 A | 121411030M | 100% |  |  | MECH DES [459.2 h]; MECH ENG [291.9 h] | 37,078.67 | 37,078.67 | 0 | 37381.011106 | WINES R | 1 | 1 |  | N/A | MIKE B |  |  |  |  |  | 2007-09-28 |  |  |  |  |  |  |  |  |  |
| 121411030M |  | S/R Dipoles & Septa Preliminary Design & Safety Review Completed (DIPOLES) | milestone | 0d | 2007-05-25 A | 2007-05-25 A | 121411030 | 100% | 2007-03-16 | 2007-03-16 |  |  |  |  | 0 | WINES R | 1 | 1 |  | N/A | MIKE B |  |  |  |  |  | 2007-03-16 |  |  | 5 |  |  |  |  |  |  |
| 121411075 |  | Detailed Dsgn of New 2m Septa (S/R Dipoles) |  | 183d | 2007-10-01 A | 2008-06-27 A | 9-080M | 100% |  |  | MECH DES [360 h]; MECH ENG [200 h] | 27,660.8 | 27,660.8 | 0 | 27660.8 | BEVINS M | 1 | 1 |  | N/A | MIKE B |  |  |  |  |  |  |  |  |  |  |  |  |  |  |  |
| 121411080 |  | Detailed Dsgn of New 2m Narrow Pole Septa (S/R Dipoles) |  | 269d | 2007-10-01 A | 2008-10-29 A | 9-080M | 100% |  |  | MECH DES [640 h]; MECH ENG [320 h] | 47,093.16 | 47,093.16 | 0 | 46976 | BEVINS M | 1 | 1 |  | N/A | MIKE B |  |  |  |  |  |  |  |  |  |  |  |  |  |  |  |
| 121411908LOE |  | FY08 Mngmnt of S/R PED Effort (S/R Dipoles) |  | 248d | 2007-10-01 A | 2008-09-30 A | 121411007LOE | 100% |  |  | MECH ENG [200 h]; SCIENTIST [160 h]; MECH TECH [200 h]; SR STAFF [680 h]; SUPPLIES & MATERIALS | 110,322.8 | 97,940 | 0 | 110322.8 | BEVINS M | 1 | 1 |  | N/A | MIKE B |  |  |  |  |  |  | 100 | 100 |  |  |  |  |  |  |  |
| 121411046 |  | Develop Detailed Dsgn of New 3m Septa (S/R Dipoles) |  | 345d | 2007-10-01 A | 2009-02-26 A | 121411060M, 9-080M, 121411020M | 100% |  |  | MECH DES [760 h]; MECH ENG [400 h] | 57,532.96 | 57,532.96 | 0 | 57020.8 | BEVINS M | 1 | 1 |  | N/A | MIKE B |  |  |  |  |  |  |  |  |  |  |  |  |  |  |  |
| 121411060M |  | Finish All New S/R C Shaped Dipoles (DIPOLES) | milestone | 0d | 2007-10-01 A | 2007-10-01 A | 121411055 | 100% | 2007-11-01 | 2007-11-01 |  |  |  |  | 0 | WINES R | 1 | 1 | 07-027 | N/A | MIKE B |  |  |  |  |  | 2007-08-21 |  |  | 5 |  |  |  |  |  |  |
| 121411036 |  | Develop Detailed Dsgn of West Curved Dipoles (S/R Dipoles) |  | 300d | 2007-10-08 A | 2008-12-22 A | 121411035 | 100% |  |  | MECH DES [240 h]; MECH ENG [120 h] | 17,722.94 | 17,722.94 | 0 | 17616 | BEVINS M | 1 | 1 |  | N/A | MIKE B |  |  |  |  |  |  |  |  |  | 09-005 |  |  |  |  |  |
| 121411065 |  | Detailed Dsgn of East Curved Dipoles (S/R Dipoles) |  | 236d | 2008-01-10 A | 2008-12-15 A | 9-080M FS+43d | 100% |  |  | MECH ENG [320 h]; MECH DES [560 h] | 43,884.31 | 43,884.31 | 0 | 43577.6 | BEVINS M | 1 | 1 |  | N/A | MIKE B |  |  |  |  |  |  |  |  |  | 09-005 |  |  |  |  |  |
| 121411909LOE |  | FY09 Mngmnt of S/R PED Effort (S/R Dipoles) |  | 248d | 2008-10-01 A | 2009-09-30 A | 121411908LOE, 121433908LOE | 100% |  |  | SCIENTIST [120 h]; SR STAFF [480 h] | 57,074.4 | 57,074.4 | 0 | 57074.4 | BEVINS M | 1 | 1 |  | E | MIKE B |  |  |  |  |  |  | 100 | 100 |  |  |  |  |  |  |  |
| 13411909LOEXD |  | FY09 Mngmnt & Oversight (S/R Dipoles) |  | 59d | 2008-10-01 A | 2008-12-24 A | 12155908LOE, 9-090M, 121411908LOE | 100% |  |  | TRAVEL; SR STAFF [123.71 h] | 19,660.87 | 12,722.34 | 0 | 19660.862957 | BEVINS M | 1 | 1 |  | E | MIKE B |  |  |  |  |  |  | 100 | 100 |  |  | 08-058 |  |  |  |  |
| 121411085 |  | Top Leg Return Dsgns for Trapezoid Dipoles (S/R Dipoles) |  | 237d | 2008-11-11 A | 2009-10-26 A | 9-090M | 100% |  |  | MECH ENG [80 h]; MECH DES [160 h] | 12,148.6 | 12,148.6 | 0 | 12119.2 | BEVINS M | 1 | 1 | 07-027 | H | MIKE B |  |  |  |  |  |  |  |  |  |  |  |  |  |  |  |
| 121411090 |  | FY08 Top Assy Dsgns for Modified S/R Dipoles (S/R Dipoles) |  | 179d | 2008-12-09 A | 2009-08-28 A | 9-080M FS+120d | 100% |  |  | MECH ENG [273.07 h]; MECH DES [887.47 h] | 56,331.28 | 56,331.28 | 0 | 54586.3744 | BEVINS M | 1 | 1 | 07-027 | S | MIKE B |  |  |  |  |  |  |  |  |  |  |  | 1.2.1.4.1.1 | EXP0809 | 09-001 | ST |
| 121411090a |  | FY09 Top Assy Dsgns for Modified S/R Dipoles (S/R Dipoles) |  | 197d | 2008-12-09 A | 2009-09-24 A | 121411090 FS-200d | 100% |  |  | MECH DES [152.53 h]; MECH ENG [46.93 h] | 9,681.52 | 9,681.52 | 0 | 9681.5185 | BEVINS M | 1 | 1 | 07-027 | S | MIKE B |  |  |  |  |  |  |  |  |  |  |  | 1.2.1.4.1.1 | EXP0809 | 09-001 | ST |
| 121411066 |  | Design Option B of East XM Curved Dipoles (S/R Dipoles) |  | 57d | 2008-12-16 A | 2009-03-16 A | 9-090M FS+41d | 100% |  |  | MECH ENG [80 h]; PLABOR | 24,118 | 5,104.8 | 0 | 24118 | BEVINS M | 1 | 1 |  | H | MIKE B |  |  |  |  |  |  |  |  |  | 09-005 |  | 1.2.1.4.1.1 |  |  |  |
| 121411038 |  | Design Option B of West XV Curved Dipoles (S/R Dipoles) |  | 46d | 2009-01-14 A | 2009-03-20 A | 9-090M FS+64d, 121411036 | 100% |  |  | MECH ENG [80 h]; PLABOR | 24,118 | 5,104.8 | 0 | 24118 | BEVINS M | 1 | 1 |  | H | MIKE B |  |  |  |  |  |  |  |  |  | 09-005 |  | 1.2.1.4.1.1 |  |  |  |
| 121411037 |  | Design Option B of West XU Curved Dipoles (S/R Dipoles) |  | 39d | 2009-02-03 A | 2009-03-30 A | 9-090M FS+69d | 100% |  |  | MECH ENG [80 h]; PLABOR | 24,118 | 5,104.8 | 0 | 24118 | BEVINS M | 1 | 1 |  | H | MIKE B |  |  |  |  |  |  |  |  |  | 09-005 |  | 1.2.1.4.1.1 |  |  |  |
| 121411081 |  | Design New Dipole for Launch into ARC 10 (S/R Dipoles) |  | 35d | 2009-02-23 A | 2009-04-10 A | 9-090M FS+105d | 100% |  |  | MECH ENG [80 h]; PLABOR | 24,118 | 5,104.8 | 0 | 24118 | BEVINS M | 1 | 1 |  | H | MIKE B |  |  |  |  |  |  |  |  |  | 09-005 |  | 1.2.1.4.1.1 |  |  |  |
| 121411050M |  | Detailed Dsgn of New 3m Septa Comp (S/R DIPOLES) | milestone | 0d | 2009-02-26 A | 2009-02-26 A | 121411045, 121411046 | 100% | 2009-03-02 | 2009-03-02 |  |  |  |  | 0 | BEVINS M | 1 | 1 |  | M | MIKE B |  |  |  |  |  |  |  |  | 6 |  |  |  |  |  |  |
| 121411070M |  | Dsgn of East Curved Dipoles Comp (S/R DIPOLES) | milestone | 0d | 2009-03-16 A | 2009-03-16 A | 121411065, 121411066 | 100% | 2009-04-07 | 2009-04-07 |  |  |  |  | 0 | BEVINS M | 1 | 1 |  | M | MIKE B |  |  |  |  |  |  |  |  | 6 | 09-005 |  |  |  |  |  |
| 121411040M |  | Dsgn of West Curved Dipoles Comp (S/R DIPOLES) | milestone | 0d | 2009-03-30 A | 2009-03-30 A | 121411036, 121411037, 121411038 | 100% | 2009-04-28 | 2009-04-28 |  |  |  |  | 0 | BEVINS M | 1 | 1 |  | M | MIKE B |  |  |  |  |  |  |  |  | 6 | 09-005 |  |  |  |  |  |
| 121411091 |  | East Option B Top Assy Dsgns for Modified S/R Dipoles (S/R Dipoles) |  | 118d | 2009-05-11 A | 2009-10-26 A | 9-090M FS+120d | 100% |  |  | MECH ENG [240 h]; PLABOR | 45,268.68 | 15,389.08 | 0 | 45194 | BEVINS M | 1 | 1 | 07-027 | H | MIKE B |  |  |  |  |  |  |  |  |  | 09-005 |  | 1.2.1.4.1.1 | EXP0809 |  |  |
| 121411092 |  | West Option B Top Assy Dsgns for Modified S/R Dipoles (S/R Dipoles) |  | 82d | 2009-07-01 A | 2009-10-26 A | 9-090M FS+142d | 100% |  |  | MECH ENG [240 h]; PLABOR | 45,301.47 | 15,421.87 | 0 | 45194 | BEVINS M | 1 | 1 | 07-027 | H | MIKE B |  |  |  |  |  |  |  |  |  | 09-005 |  | 1.2.1.4.1.1 | EXP0809 |  |  |
| 121411110M |  | All S/R Dipole & Septa Dsgns Comp (S/R DIPOLES)++ | milestone | 0d | 2009-10-26 A | 2009-10-26 A | 121411070M, 121411090a, 121411085, 121411092, 121411081, 121411090, 121411091, 121411075, 121411050M, 121411080, 121411040M | 100% | 2009-11-30 | 2009-11-30 |  |  |  |  | 0 | BEVINS M | 1 | 1 |  | M | MIKE B |  |  |  |  |  |  |  |  | 6 | 09-005 |  |  |  |  |  |
| 121411120 |  | Re-Baseline Actuals Adjustment |  | 1d | 2013-08-30 A | 2013-08-30 A |  | 100% | 2013-09-03 | 2013-09-03 | PROCUREMENT>$50K 69 NO ESCALATION | 147,016.32 |  |  | 147016.32 |  |  |  |  |  |  | 0 | 147016.32 | 14701632 | 100 | ADJ |  |  |  |  |  |  |  |  |  |  |

Notes:
- 121411090: Steps: Core Modifications and H-steel of S/R Dipoles (done); Parts updated for S/R Dipoles (done); Top Assembly of East S/R Dipoles (done); Top Assembly of West S/R Dipoles (done)
- 121411090a: Steps: Core Modifications and H-steel of S/R Dipoles (done); Parts updated for S/R Dipoles (done); Top Assembly of East S/R Dipoles (done); Top Assembly of West S/R Dipoles (done)

| ID | WBS | Activity | Type | Duration | Start | Finish | Predecessors | Complete | Planned start | Planned finish | Resources | Cost | Actual cost | Planned FinishUDF | Calculated Remaining Total Cost | MONTHLY EV COST | RESP - Responsibility | STRT%COMP for CM EVM | FNSH%COMP for CM EVM | EVMS Reporting Codes | CAM RESPONSIBLE | Milestone Level | ACT BRIDGING FY SPLIT | WBS ASSIGNMENT | EXPNS ACT BRIDGING FY SPLIT | CR 09-001 | CR 07-027 | Activities with Steps | CR 09-005 | Claimed Material Divider | ReBaseline Actuals Adjustment | CR 10-065 | LOE Divider | LOE Multiplier | CR 08-029 | CR 08-058 |
| --- | --- | --- | --- | --- | --- | --- | --- | --- | --- | --- | --- | --- | --- | --- | --- | --- | --- | --- | --- | --- | --- | --- | --- | --- | --- | --- | --- | --- | --- | --- | --- | --- | --- | --- | --- | --- |
|  | 2 | **1.2.1.4.1.2 QUADRUPOLES** |  |  |  |  |  |  |  |  |  |  |  |  |  |  |  |  |  |  |  |  |  |  |  |  |  |  |  |  |  |  |  |  |  |  |
|  | 3 | **1.2.1.4.1.3 CORRECTORS** |  |  |  |  |  |  |  |  |  |  |  |  |  |  |  |  |  |  |  |  |  |  |  |  |  |  |  |  |  |  |  |  |  |  |
|  | 4 | **1.2.1.4.1.4 STANDS** |  |  | 2006-10-02 | 2013-08-30 |  |  |  |  |  |  |  |  |  |  |  |  |  |  |  |  |  |  |  |  |  |  |  |  |  |  |  |  |  |  |
| 121414005 |  | Develop Preliminary S/R Stand and Layout Design (STANDS) |  | 184d | 2006-10-02 A | 2007-06-29 A | 9-070M FS+22d | 100% |  |  | MECH DES [522 h]; MECH ENG [313.2 h] | 42,405.05 | 42,405.05 | 2007-04-17 | 0 | 42458.891563 | BEVINS M | 1 | 1 | N/A | MIKE B |  |  |  |  |  |  |  |  |  |  |  |  |  |  |  |
| 121414010 |  | Preliminary Design & Safety Review of Stands (STANDS) |  | 19d | 2007-05-01 A | 2007-05-28 A | 121414005 FS-20d | 100% | 2007-05-01 | 2007-05-25 | MECH DES [34.8 h]; MECH ENG [34.8 h] | 3,680.79 | 3,680.79 | 2007-04-17 | 0 | 3685.2504 | BEVINS M | 1 | 1 | N/A | MIKE B |  |  |  |  |  |  |  |  |  |  |  |  |  |  |  |
| 121414010M |  | Preliminary S/R Stand and Layout Design & Safety Review Completed (STANDS) | milestone | 0d | 2007-05-28 A | 2007-05-28 A | 121414010 | 100% | 2007-04-17 | 2007-04-17 |  |  |  | 2007-04-17 |  | 0 | BEVINS M | 1 | 1 | N/A | MIKE B | 5 |  |  |  |  |  |  |  |  |  |  |  |  |  |  |
| 121414015 |  | FY08 Detailed Dsgn of East S/R (S/R Stands) PED++ |  | 246.02d | 2008-01-02 A | 2008-12-22 A | 9-080M FS+58d, 121414010M | 100% |  |  | PLABOR; MECH ENG [360 h]; MECH DES [1120 h] | 98,209.6 | 70,348.3 |  | 0 | 97701.3 | BEVINS M | 1 | 1 | N/A | MIKE B |  | FY08-09 | 1.2.1.4.1.4 | EXP0809 | 09-001 |  |  |  |  |  |  |  |  |  |  |
| 121414020 |  | FY08 Detailed Dsgn of West S/R (S/R Stands)++ |  | 224d | 2008-11-03 A | 2009-09-29 A | 9-080M FS+135d | 100% |  |  | PLABOR; MECH ENG [301.33 h]; MECH DES [891.44 h] | 75,799.31 | 58,308.6 |  | 0 | 73993.3284 | BEVINS M | 1 | 1 | S | MIKE B |  | FY08-09 | 1.2.1.4.1.4 | EXP0809 | 09-001 | 07-027 | ST |  |  |  |  |  |  |  |  |
| 121414020a |  | FY09 Detailed Dsgn of West S/R (S/R Stands)++ |  | 243d | 2008-11-03 A | 2009-10-26 A | 121414020 FS-250d | 100% |  |  | PLABOR; MECH ENG [658.67 h]; MECH DES [1948.56 h] | 167,207.7 | 127,756.21 |  | 0 | 166906.0931 | BEVINS M | 1 | 1 | S | MIKE B |  | FY08-09 | 1.2.1.4.1.4 | EXP0809 | 09-001 | 07-027 | ST |  |  |  |  |  |  |  |  |
| 121414015a |  | FY09 Detailed Dsgn of East S/R (S/R Stands) PED++ |  | 63d | 2008-12-23 A | 2009-03-31 A | 121414015 | 100% |  |  | PLABOR; MECH DES [1120 h]; MECH ENG [360 h] | 100,822.48 | 72,072.4 |  | 0 | 100822.48 | BEVINS M | 1 | 1 | N/A | MIKE B |  | FY08-09 | 1.2.1.4.1.4 | EXP0809 | 09-001 |  |  |  |  |  |  |  |  |  |  |
| 121414016 |  | Incorporate Changes B to the Modified East S/R (S/R Dipoles) |  | 125d | 2009-04-01 A | 2009-09-25 A | 9-090M FS+98d | 100% |  |  | MECH ENG [320 h]; PLABOR | 112,768 | 20,419.2 |  | 0 | 112768 | BEVINS M | 1 | 1 | S | MIKE B |  |  | 1.2.1.4.1.1 | EXP0809 |  | 07-027 | ST | 09-005 |  |  |  |  |  |  |  |
| 121414025 |  | Re-Baseline Actuals Adjustment |  | 1d | 2013-08-30 A | 2013-08-30 A |  | 100% | 2013-09-03 | 2013-09-03 | PROCUREMENT>$50K 69 NO ESCALATION | -8,517 |  |  |  |  |  |  |  |  |  |  |  |  |  |  |  |  |  | 100 | ADJ |  |  |  |  |  |
|  | 5 | **1.2.1.4.1.5 GIRDERS** |  |  |  |  |  |  |  |  |  |  |  |  |  |  |  |  |  |  |  |  |  |  |  |  |  |  |  |  |  |  |  |  |  |  |
|  | 6 | **1.2.1.4.1.6 VACUUM** |  |  | 2008-11-03 | 2013-08-30 |  |  |  |  |  |  |  |  |  |  |  |  |  |  |  |  |  |  |  |  |  |  |  |  |  |  |  |  |  |  |
| 121416000 |  | FY08 Detailed Dsgn of East S/R Dipole Chambers (S/R Vac)++ |  | 266d | 2008-11-03 A | 2009-11-30 A | 9-080M FS+80d | 100% |  |  | MECH DES [705.6 h]; MECH ENG [218.4 h] | 45,090.55 | 45,090.55 |  | 0 | 43479.744 | BEVINS M | 1 | 1 | S | MIKE B |  |  | 1.2.1.4.1.6 | EXP0809 | 09-001 | 07-027 | ST |  |  |  | 10-065 |  |  |  |  |
| 121416000a |  | FY09 Detailed Dsgn of East S/R Dipole Chambers (S/R Vac)++ |  | 266d | 2008-11-03 A | 2009-11-30 A | 121416000 FS-250d | 100% |  |  | MECH ENG [41.6 h]; MECH DES [134.4 h] | 8,588.68 | 8,588.68 |  | 0 | 8546.592 | BEVINS M | 1 | 1 | S | MIKE B |  |  | 1.2.1.4.1.6 | EXP0809 | 09-001 | 07-027 | ST |  |  |  | 10-065 |  |  |  |  |
| 121416005 |  | FY08 Detailed Dsgn of West S/R Dipole Chambers (S/R Vac)++ |  | 187d | 2009-02-02 A | 2009-10-26 A | 121416000a FS-250d | 100% |  |  | MECH DES [393.33 h]; MECH ENG [78.67 h] | 22,331.97 | 22,331.97 |  | 0 | 21573.6112 | BEVINS M | 1 | 1 | S | MIKE B |  |  | 1.2.1.4.1.6 | EXP0809 | 09-001 | 07-027 | ST |  |  |  |  |  |  |  |  |
| 121416005a |  | FY09 Detailed Dsgn of West S/R Dipole Chambers (S/R Vac)++ |  | 187d | 2009-02-02 A | 2009-10-26 A | 121416005 FS-250d | 100% |  |  | MECH ENG [1.33 h]; MECH DES [6.67 h] | 378.44 | 378.44 |  | 0 | 377.2801 | BEVINS M | 1 | 1 | S | MIKE B |  |  | 1.2.1.4.1.6 | EXP0809 | 09-001 | 07-027 | ST |  |  |  |  |  |  |  |  |
| 121416010 |  | Pre-Constrctn Dsgn Review for S/R's++ |  | 6d | 2009-10-19 A | 2009-10-26 A | 121411110M FS-40d, 121416005a, 121414020a FS-300d, 121416000 FS-60d, 121414016, 121414015a FS-300d, 121416000a FS-60d | 100% |  |  |  |  |  |  |  | 0 | BEVINS M | 1 | 1 | Z | MIKE B |  |  |  |  |  |  |  | 09-005 |  |  | 10-065 |  |  |  |  |
| 121416015 |  | Re-Baseline Actuals Adjustment |  | 1d | 2013-08-30 A | 2013-08-30 A |  | 100% | 2013-09-03 | 2013-09-03 | PROCUREMENT>$50K 69 NO ESCALATION | -36,756.97 |  |  |  |  |  |  |  |  |  |  |  |  |  |  |  |  |  | 100 | ADJ |  |  |  |  |  |
|  | 7 | **1.2.1.4.1.7 INSTALLATION** |  |  |  |  |  |  |  |  |  |  |  |  |  |  |  |  |  |  |  |  |  |  |  |  |  |  |  |  |  |  |  |  |  |  |
|  | 2 | **1.2.1.4.2 EXISTING ARCS (1-9, A, B, & C)** |  |  | 2006-10-02 | 2013-08-30 |  |  |  |  |  |  |  |  |  |  |  |  |  |  |  |  |  |  |  |  |  |  |  |  |  |  |  |  |  |  |
|  | 1 | **1.2.1.4.2.1 DIPOLES** |  |  | 2006-10-02 | 2013-08-30 |  |  |  |  |  |  |  |  |  |  |  |  |  |  |  |  |  |  |  |  |  |  |  |  |  |  |  |  |  |  |
| 121421005 |  | Develop Partial Design of Arc Dipole H-Iron (DIPOLES) |  | 120d | 2006-10-02 A | 2007-03-30 A | 9-070M | 100% |  |  | MECH ENG [139.2 h]; MECH DES [278.4 h] | 20,938.46 | 20,938.46 | 2007-02-01 | 0 | 20938.464 | WINES R | 1 | 1 | N/A | MIKE B |  |  |  |  |  |  |  |  |  |  |  |  |  |  |  |
| 121421010 |  | Preliminary Design & Safety Review of Existing Arcs Dipoles (DIPOLES) |  | 19d | 2007-01-29 A | 2007-02-23 A | 121421005 FS-20d | 100% |  |  | MECH DES [34.8 h]; MECH ENG [34.8 h] | 3,691.93 | 3,691.93 | 2007-02-01 | 0 | 3691.932 | WINES R | 1 | 1 | N/A | MIKE B |  |  |  |  |  |  |  |  |  |  |  |  |  |  |  |
| 121421010M |  | Existing Arcs Dipoles Preliminary Design & Safety Review Completed (DIPOLES) | milestone | 0d | 2007-02-23 A | 2007-02-23 A | 121421005, 121421010, 121424005 | 100% | 2007-02-01 | 2007-02-01 |  |  |  | 2007-02-01 |  | 0 | WINES R | 1 | 1 | N/A | MIKE B | 5 |  |  |  |  |  |  |  |  |  |  |  |  |  |  |
| 121421908LOE |  | FY08 Mngmnt of Existing Arcs (EXIST ARC Dipoles) |  | 248d | 2007-10-01 A | 2008-09-30 A | 9-080M, 121411007LOE | 100% |  |  | SUPPLIES & MATERIALS; SR STAFF [240 h] | 45,753.4 | 23,918.4 |  | 0 | 45753.404 | BEVINS M | 1 | 1 | N/A | MIKE B |  |  |  |  |  |  |  |  |  |  |  | 100 | 100 |  |  |
| 121421020 |  | Finish Dsgn of Arc Dipole H-Iron (EXIST ARC Dipoles) ++ |  | 319d | 2008-04-21 A | 2009-07-30 A | 121421010M, 9-090M | 100% |  |  | MECH ENG [80 h]; MECH DES [360 h] | 20,655.91 | 20,655.91 |  | 0 | 20887.2 | BEVINS M | 1 | 1 | H | MIKE B |  |  |  |  |  | 07-027 |  |  |  |  |  |  |  |  |  |
| 13421909LOEXD |  | FY09 Mngmnt & Oversight (EXIST ARC Dipoles) |  | 59d | 2008-10-01 A | 2008-12-24 A | 121421908LOE | 100% |  |  | SR STAFF [66.61 h]; TRAVEL | 12,339.62 | 6,850.17 |  | 0 | 12339.622425 | BEVINS M | 1 | 1 | E | MIKE B |  |  |  |  |  |  |  |  |  |  |  | 100 | 100 | 08-029 | 08-058 |
| 121421021 |  | Add H Steel to ARC 1 & 2 Design (S/R Dipoles) |  | 52d | 2009-05-18 A | 2009-07-30 A | 121421020 FS-100d | 100% |  |  | MECH ENG [120 h]; PLABOR | 21,239 | 7,657.2 |  | 0 | 21239 | BEVINS M | 1 | 1 | H | MIKE B |  |  | 1.2.1.4.1.1 | EXP0809 |  | 07-027 |  | 09-005 |  |  | 10-065 |  |  |  |  |
| 121421022 |  | Synchrotron Radiation Compensation Design (S/R Dipoles) |  | 43d | 2009-07-01 A | 2009-08-31 A | 121421021 FS-1d | 100% |  |  | MECH ENG [160 h]; PLABOR | 23,792 | 10,209.6 |  | 0 | 23792 | BEVINS M | 1 | 1 | H | MIKE B |  |  | 1.2.1.4.1.1 | EXP0809 |  | 07-027 |  | 09-005 |  |  | 10-065 |  |  |  |  |
| 121421025 |  | Re-Baseline Actuals Adjustment |  | 1d | 2013-08-30 A | 2013-08-30 A |  | 100% | 2013-09-03 | 2013-09-03 | PROCUREMENT>$50K 69 NO ESCALATION | -79,179.11 |  |  |  |  |  |  |  |  |  |  |  |  |  |  |  |  |  | 100 | ADJ |  |  |  |  |  |

Notes:
- 121414015: Corrective Actions: Changed Purchased labor from $34K to $54K based on input from LH 050907 - / RKC / From MWiseman Rev B -2.xls
- 121414020: Corrective Actions: Changed Purchased labor from $34K to $54K based on input from LH 050907 - / RKC / From MWiseman Rev B -2.xls / Steps: West S/R Layouts developed with CASA (done); Design West S/R New/Modified Quad Girders (done); Detail West S/R New/Modified Quad Girders (done); Design West S/R Stands and Brackets (done); Detail West S/R Stands and Brackets (done)
- 121414020a: Corrective Actions: Changed Purchased labor from $34K to $54K based on input from LH 050907 - / RKC / From MWiseman Rev B -2.xls / Steps: West S/R Layouts developed with CASA (done); Design West S/R New/Modified Quad Girders (done); Detail West S/R New/Modified Quad Girders (done); Design West S/R Stands and Brackets (done); Detail West S/R Stands and Brackets (done)
- 121414015a: Corrective Actions: Changed Purchased labor from $34K to $54K based on input from LH 050907 - / RKC / From MWiseman Rev B -2.xls
- 121414016: Steps: Design & Detail East Modified Girders (done); Design East Stands (done); Design East Brackets (done); Detail East Stands & Brackets (done); Layout NE and SE Spreader Region (done)
- 121416000: Steps: East S/R Dipole/Septa Layouts developed with CASA (done); Engineering Vacuum Design Complete (done); Overall Vacuum Design Complete (done); Design of Vacuum Chambers Complete (done); Detail East S/R Vac Chambers (done)
- 121416000a: Steps: East S/R Dipole/Septa Layouts developed with CASA (done); Engineering Vacuum Design Complete (done); Overall Vacuum Design Complete (done); Design of Vacuum Chambers Complete (done); Detail East S/R Vac Chambers (done)
- 121416005: Steps: West S/R Dipole/Septa Layouts developed with CASA (done); Engineering Vacuum Design Complete (done); Overall Vacuum Design Complete (done); Design of Vacuum Chambers Complete (done); Detail West S/R Vac Chambers (done)
- 121416005a: Steps: West S/R Dipole/Septa Layouts developed with CASA (done); Engineering Vacuum Design Complete (done); Overall Vacuum Design Complete (done); Design of Vacuum Chambers Complete (done); Detail West S/R Vac Chambers (done)
- 121416010: Explanation: Removed Neg lag From / Pred.

| ID | WBS | Activity | Duration | Start | Finish | Predecessors | Complete | Planned start | Planned finish | Resources | Cost | Actual cost | Calculated Remaining Total Cost | MONTHLY EV COST | RESP - Responsibility | STRT%COMP for CM EVM | FNSH%COMP for CM EVM | EVMS Reporting Codes | CAM RESPONSIBLE | CR 08-029 | CR 08-058 | Claimed Material Divider | ReBaseline Actuals Adjustment | Planned FinishUDF | CR 07-003 | CR 07-027 | Remaining Material Cost Based on % Compl | Claimed Material Cost Based on % Complet | Initial Claimed Material Calc | LOE Divider | LOE Multiplier |
| --- | --- | --- | --- | --- | --- | --- | --- | --- | --- | --- | --- | --- | --- | --- | --- | --- | --- | --- | --- | --- | --- | --- | --- | --- | --- | --- | --- | --- | --- | --- | --- |
|  | 2 | **1.2.1.4.2.2 QUADRUPOLES** |  | 2008-10-03 | 2013-08-30 |  |  |  |  |  |  |  |  |  |  |  |  |  |  |  |  |  |  |  |  |  |  |  |  |  |  |
| 13422035XD |  | Prcrmnt Prep for Quads (EXIST ARC Q-POLES) | 56d | 2008-10-03 A | 2008-12-23 A | 9-090M | 100% |  |  | MECH ENG [77.8 h]; MECH DES [51.87 h] | 7,238.4 | 7,238.4 | 0 | 7238.3988 | BEVINS M | 1 | 1 | H | MIKE B | 08-029 | 08-058 |  |  |  |  |  |  |  |  |  |  |
| 121422000 |  | Re-Baseline Actuals Adjustment | 1d | 2013-08-30 A | 2013-08-30 A |  | 100% | 2013-09-03 | 2013-09-03 | PROCUREMENT>$50K 69 NO ESCALATION | -6,312.01 |  |  |  |  |  |  |  |  |  |  | 100 | ADJ |  |  |  |  |  |  |  |  |
|  | 3 | **1.2.1.4.2.3 CORRECTORS** |  |  |  |  |  |  |  |  |  |  |  |  |  |  |  |  |  |  |  |  |  |  |  |  |  |  |  |  |  |
|  | 4 | **1.2.1.4.2.4 STANDS** |  | 2006-10-16 | 2013-08-30 |  |  |  |  |  |  |  |  |  |  |  |  |  |  |  |  |  |  |  |  |  |  |  |  |  |  |
| 121424005 |  | Develop Cartridge Design for Path Length Change (STANDS) | 103d | 2006-10-16 A | 2007-03-21 A | 9-070M FS+10d | 100% |  |  | MECH ENG [34.8 h]; MECH DES [69.6 h] | 5,234.62 | 5,234.62 | 0 | 5234.616 | BEVINS M | 1 | 1 | N/A | MIKE B |  |  |  |  | 2006-12-19 | 07-003 |  |  |  |  |  |  |
| 121425005 |  | Dsgn of Modifed QR & QC/QB Girders (EXIST ARC Girders) | 149d | 2008-03-03 A | 2008-09-30 A | 9-080M FS+75d | 100% |  |  | MECH DES [240 h]; MECH ENG [80 h] | 15,142.4 | 15,142.4 | 0 | 15142.4 | BEVINS M | 1 | 1 | N/A | MIKE B |  |  |  |  |  |  |  |  |  |  |  |  |
| 121425010 |  | Dsgn of simple QR Girder for H-B (EXIST ARC Girders)++ | 40d | 2008-07-21 A | 2008-09-15 A | 121425005 FS-50d | 100% |  |  | MECH DES [120 h]; MECH ENG [40 h] | 7,571.2 | 7,571.2 | 0 | 7571.2 | BEVINS M | 1 | 1 | H | MIKE B |  |  |  |  |  |  |  |  |  |  |  |  |
| 121424010 |  | New Stands for H-B Transport (EXIST ARC Stands)+ | 42d | 2008-08-01 A | 2008-09-30 A | 9-090M | 100% |  |  | MECH ENG [80 h]; MECH DES [320 h] | 18,540.8 | 18,540.8 | 0 | 19133.6 | BEVINS M | 1 | 1 | H | MIKE B |  |  |  |  |  |  | 07-027 |  |  |  |  |  |
| 121425015 |  | Pre-Constrctn Dsgn Review for Existing ARCs++ | 11d | 2009-10-05 A | 2009-10-19 A | 121421020, 121425010, 121424010 | 100% |  |  |  |  |  |  | 0 | BEVINS M | 1 | 1 | Z | MIKE B |  |  |  |  |  |  | 07-027 |  |  |  |  |  |
| 121424015 |  | Re-Baseline Actuals Adjustment | 1d | 2013-08-30 A | 2013-08-30 A |  | 100% | 2013-09-03 | 2013-09-03 | PROCUREMENT>$50K 69 NO ESCALATION | 12,344.88 |  |  | 12344.88 |  |  |  |  |  |  |  | 100 | ADJ |  |  |  | 0 | 12344.88 | 1234488 |  |  |
|  | 5 | **1.2.1.4.2.5 GIRDERS** |  |  |  |  |  |  |  |  |  |  |  |  |  |  |  |  |  |  |  |  |  |  |  |  |  |  |  |  |  |
|  | 6 | **1.2.1.4.2.6 VACUUM** |  |  |  |  |  |  |  |  |  |  |  |  |  |  |  |  |  |  |  |  |  |  |  |  |  |  |  |  |  |
|  | 7 | **1.2.1.4.2.7 INSTALLATION** |  |  |  |  |  |  |  |  |  |  |  |  |  |  |  |  |  |  |  |  |  |  |  |  |  |  |  |  |  |
|  | 3 | **1.2.1.4.3 LINACS** |  | 2007-02-08 | 2013-08-30 |  |  |  |  |  |  |  |  |  |  |  |  |  |  |  |  |  |  |  |  |  |  |  |  |  |  |
|  | 1 | **1.2.1.4.3.1 QUADRUPOLES** |  |  |  |  |  |  |  |  |  |  |  |  |  |  |  |  |  |  |  |  |  |  |  |  |  |  |  |  |  |
|  | 2 | **1.2.1.4.3.2 CORRECTORS** |  | 2008-07-21 | 2013-08-30 |  |  |  |  |  |  |  |  |  |  |  |  |  |  |  |  |  |  |  |  |  |  |  |  |  |  |
| 121432005 |  | Final Dsgn of Linac Correctors & Skew Quads (Linac Correctors)++ | 272d | 2008-07-21 A | 2009-08-21 A | 9-080M FS+200d | 100% |  |  | MECH ENG [80 h]; MECH DES [120 h] | 10,305.45 | 10,305.45 | 0 | 10044.8 | BEVINS M | 1 | 1 | H | MIKE B |  |  |  |  |  |  | 07-027 |  |  |  |  |  |
| 121432010 |  | Re-Baseline Actuals Adjustment | 1d | 2013-08-30 A | 2013-08-30 A |  | 100% | 2013-09-03 | 2013-09-03 | PROCUREMENT>$50K 69 NO ESCALATION | 191.78 |  |  | 191.78 |  |  |  |  |  |  |  | 100 | ADJ |  |  |  | 0 | 191.78 | 19178 |  |  |
|  | 3 | **1.2.1.4.3.3 STANDS** |  | 2007-02-08 | 2013-08-30 |  |  |  |  |  |  |  |  |  |  |  |  |  |  |  |  |  |  |  |  |  |  |  |  |  |  |
| 121433005 |  | Initial layout of LINAC Stands and Girders (STANDS) | 71d | 2007-02-08 A | 2007-05-18 A | 9-070M FS+79d | 100% |  |  | MECH ENG [69.6 h]; MECH DES [139.2 h] | 10,437.66 | 10,437.66 | 0 | 10436.086024 | BEVINS M | 1 | 1 | N/A | MIKE B |  |  |  |  | 2007-06-01 | 07-003 |  |  |  |  |  |  |
| 121433908LOE |  | FY08 Mngmnt of Linac Stands | 248d | 2007-10-01 A | 2008-09-30 A | 121411007LOE, 9-080M | 100% |  |  |  |  |  |  | 0 | BEVINS M | 1 | 1 | N/A | MIKE B |  |  |  |  |  |  |  |  |  |  | 100 | 100 |
| 121434005 |  | Final Dsgn of Linac Girders (Linac Girders)++ | 299d | 2007-12-05 A | 2009-02-25 A | 9-080M FS+200d | 100% |  |  | MECH DES [120 h]; MECH ENG [120 h] | 12,646.7 | 12,646.7 | 0 | 12518.4 | BEVINS M | 1 | 1 | N/A | MIKE B |  |  |  |  |  |  | 07-027 |  |  |  |  |  |
| 121434999 |  | Pre-Constrctn Dsgn Review for Linacs++ | 3d | 2009-10-02 A | 2009-10-06 A | 121432005, 121434005 | 100% |  |  |  |  |  |  | 0 | BEVINS M | 1 | 1 | Z | MIKE B |  |  |  |  |  |  | 07-027 |  |  |  |  |  |
| 121433010 |  | Re-Baseline Actuals Adjustment | 1d | 2013-08-30 A | 2013-08-30 A |  | 100% | 2013-09-03 | 2013-09-03 | PROCUREMENT>$50K 69 NO ESCALATION | 23,309.31 |  |  | 23309.31 |  |  |  |  |  |  |  | 100 | ADJ |  |  |  | 0 | 23309.31 | 2330931 |  |  |

| ID | WBS | Activity | Type | Duration | Start | Finish | Predecessors | Complete | Planned start | Planned finish | Resources | Cost | Actual cost | Planned FinishUDF | Calculated Remaining Total Cost | MONTHLY EV COST | RESP - Responsibility | STRT%COMP for CM EVM | FNSH%COMP for CM EVM | EVMS Reporting Codes | CAM RESPONSIBLE | CR 07-027 | WBS ASSIGNMENT | EXPNS ACT BRIDGING FY SPLIT | CR 09-001 | Remaining Material Cost Based on % Compl | Claimed Material Cost Based on % Complet | Initial Claimed Material Calc | Claimed Material Divider | ReBaseline Actuals Adjustment | Milestone Level | LOE Divider | LOE Multiplier | CR 08-058 |
| --- | --- | --- | --- | --- | --- | --- | --- | --- | --- | --- | --- | --- | --- | --- | --- | --- | --- | --- | --- | --- | --- | --- | --- | --- | --- | --- | --- | --- | --- | --- | --- | --- | --- | --- |
|  | 4 | **1.2.1.4.3.4 GIRDERS** |  |  |  |  |  |  |  |  |  |  |  |  |  |  |  |  |  |  |  |  |  |  |  |  |  |  |  |  |  |  |  |  |
|  | 5 | **1.2.1.4.3.5 VACUUM** |  |  |  |  |  |  |  |  |  |  |  |  |  |  |  |  |  |  |  |  |  |  |  |  |  |  |  |  |  |  |  |  |
|  | 6 | **1.2.1.4.3.6 INSTALLATION** |  |  |  |  |  |  |  |  |  |  |  |  |  |  |  |  |  |  |  |  |  |  |  |  |  |  |  |  |  |  |  |  |
|  | 4 | **1.2.1.4.4 INJECTOR & RE-INJECTION** |  |  | 2007-02-15 | 2013-08-30 |  |  |  |  |  |  |  |  |  |  |  |  |  |  |  |  |  |  |  |  |  |  |  |  |  |  |  |  |
|  | 1 | **1.2.1.4.4.1 DIPOLES** |  |  | 2007-03-19 | 2013-08-30 |  |  |  |  |  |  |  |  |  |  |  |  |  |  |  |  |  |  |  |  |  |  |  |  |  |  |  |  |
| 121441005 |  | Develop Preliminary Design of Re-injection Dipoles (DIPOLES) |  | 45d | 2007-03-19 A | 2007-05-18 A | 9-070M FS+108d | 100% |  |  | MECH ENG [104.4 h]; MECH DES [69.6 h] | 9,523.37 | 9,523.37 | 2007-06-14 | 0 | 9522.896861 | WINES R | 1 | 1 | N/A | MIKE B |  |  |  |  |  |  |  |  |  |  |  |  |  |
| 121441010 |  | FY08 Final Dsgn of Re-injection Dipoles (INJ/RE-INJ Dipoles)++ |  | 176.97d | 2008-01-04 A | 2008-09-15 A | 9-080M FS+200d | 100% |  |  | MECH DES [320 h]; MECH ENG [96 h] | 19,530.24 | 19,530.24 |  | 0 | 19530.24 | BEVINS M | 1 | 1 | N/A | MIKE B | 07-027 | 1.2.1.4.4.1 | EXP0809 | 09-001 |  |  |  |  |  |  |  |  |  |
| 121441010a |  | FY09 Final Dsgn of Re-injection Dipoles (INJ/RE-INJ Dipoles)++ |  | 238d | 2008-09-16 A | 2009-08-31 A | 121441010 | 100% |  |  | MECH DES [80 h]; MECH ENG [24 h] | 5,031.42 | 5,031.42 |  | 0 | 5038.64 | BEVINS M | 1 | 1 | N/A | MIKE B | 07-027 | 1.2.1.4.4.1 | EXP0809 | 09-001 |  |  |  |  |  |  |  |  |  |
| 121441015 |  | Re-Baseline Actuals Adjustment |  | 1d | 2013-08-30 A | 2013-08-30 A |  | 100% | 2013-09-03 | 2013-09-03 | PROCUREMENT>$50K 69 NO ESCALATION | 5,697.07 |  |  |  | 5697.07 |  |  |  |  |  |  |  |  |  | 0 | 5697.07 | 569707 | 100 | ADJ |  |  |  |  |
|  | 2 | **1.2.1.4.4.2 QUADRUPOLES** |  |  |  |  |  |  |  |  |  |  |  |  |  |  |  |  |  |  |  |  |  |  |  |  |  |  |  |  |  |  |  |  |
|  | 3 | **1.2.1.4.4.3 CORRECTORS** |  |  |  |  |  |  |  |  |  |  |  |  |  |  |  |  |  |  |  |  |  |  |  |  |  |  |  |  |  |  |  |  |
|  | 4 | **1.2.1.4.4.4 STANDS** |  |  | 2007-02-15 | 2013-08-30 |  |  |  |  |  |  |  |  |  |  |  |  |  |  |  |  |  |  |  |  |  |  |  |  |  |  |  |  |
| 121444010 |  | Preliminary Design & Safety Review of Layout & Stand Design |  | 66d | 2007-02-15 A | 2007-05-18 A | 121444005 FS-20d | 100% |  |  | MECH DES [34.8 h]; MECH ENG [34.8 h] | 3,686.03 | 3,686.03 | 2007-06-11 | 0 | 3680.796 | BEVINS M | 1 | 1 | N/A | MIKE B |  |  |  |  |  |  |  |  |  |  |  |  |  |
| 121444005 |  | Develop Preliminary Layout & Stand Design |  | 55d | 2007-03-05 A | 2007-05-18 A | 9-070M FS+80d | 100% |  |  | MECH DES [208.8 h]; MECH ENG [139.2 h] | 17,798.17 | 17,798.17 | 2007-06-11 | 0 | 17805.149333 | BEVINS M | 1 | 1 | N/A | MIKE B |  |  |  |  |  |  |  |  |  |  |  |  |  |
| 121444010M |  | Re-Injection & Linac Preliminary Design & Safety Review Completed | milestone | 0d | 2007-05-18 A | 2007-05-18 A | 121444010, 121441005, 121433005 | 100% | 2007-06-14 | 2007-06-14 |  |  |  | 2007-06-14 |  | 0 | BEVINS M | 1 | 1 | N/A | MIKE B |  |  |  |  |  |  |  |  |  | 5 |  |  |  |
| 121444015 |  | Detailed Dsgn of Re-Injection Line & Stands (Injector & Re-Injection Stands)++ |  | 83d | 2007-11-12 A | 2008-03-21 A | 9-080M, 121444010M | 100% | 2007-11-12 | 2008-03-20 | MECH ENG [320 h]; MECH DES [520 h] | 41,878.4 | 41,878.4 |  | 0 | 41878.4 | BEVINS M | 1 | 1 | N/A | MIKE B |  |  |  |  |  |  |  |  |  |  |  |  |  |
| 121444020 |  | Detailed Dsgn of Spectrometer Move (Injector & Re-Injection Stands)++ |  | 153d | 2008-01-10 A | 2008-08-15 A | 121444015 | 100% |  |  | MECH ENG [280 h]; MECH DES [480 h] | 37,705.6 | 37,705.6 |  | 0 | 37705.6 | BEVINS M | 1 | 1 | N/A | MIKE B |  |  |  |  |  |  |  |  |  |  |  |  |  |
| 13444909LOEXD |  | FY09 Mngmnt/Planning for Reinjection Modifications (INJ/RE-INJ Stands) |  | 59d | 2008-10-01 A | 2008-12-24 A | 121411908LOE, 9-090M | 100% |  |  | MECH DES [38.06 h]; SR STAFF [47.58 h] | 6,561.68 | 6,561.68 |  | 0 | 6561.6776 | BEVINS M | 1 | 1 | E | MIKE B |  |  |  |  |  |  |  |  |  |  | 100 | 100 | 08-058 |
| 121444025 |  | Re-Baseline Actuals Adjustment |  | 1d | 2013-08-30 A | 2013-08-30 A |  | 100% | 2013-09-03 | 2013-09-03 | PROCUREMENT>$50K 69 NO ESCALATION | 25,366.41 |  |  |  | 25366.41 |  |  |  |  |  |  |  |  |  | 0 | 25366.41 | 2536641 | 100 | ADJ |  |  |  |  |
|  | 5 | **1.2.1.4.4.5 GIRDERS** |  |  |  |  |  |  |  |  |  |  |  |  |  |  |  |  |  |  |  |  |  |  |  |  |  |  |  |  |  |  |  |  |
|  | 6 | **1.2.1.4.4.6 VACUUM** |  |  | 2008-03-10 | 2013-08-30 |  |  |  |  |  |  |  |  |  |  |  |  |  |  |  |  |  |  |  |  |  |  |  |  |  |  |  |  |
| 121446005 |  | Dsgn New Vac Chambers for Re-Injections (INJ/RE-INJ Vac)++ |  | 80d | 2008-03-10 A | 2008-06-30 A | 9-080M FS+205d | 100% |  |  | MECH ENG [20 h]; MECH DES [200 h] | 9,732.8 | 9,732.8 |  | 0 | 9732.8 | BEVINS M | 1 | 1 | N/A | MIKE B | 07-027 |  |  |  |  |  |  |  |  |  |  |  |  |
| 121446999 |  | Pre-Constrctn Dsgn Review for Injector & Re-Injection+ |  | 2d | 2009-10-02 A | 2009-10-05 A | 121444015, 121446005, 121444020, 121441010a | 100% |  |  |  |  |  |  |  | 0 | BEVINS M | 1 | 1 | Z | MIKE B | 07-027 |  |  |  |  |  |  |  |  |  |  |  |  |
| 121446010 |  | Re-Baseline Actuals Adjustment |  | 1d | 2013-08-30 A | 2013-08-30 A |  | 100% | 2013-09-03 | 2013-09-03 | PROCUREMENT>$50K 69 NO ESCALATION | -9,733.4 |  |  |  |  |  |  |  |  |  |  |  |  |  |  |  |  | 100 | ADJ |  |  |  |  |

| ID | WBS | Activity | Type | Duration | Start | Finish | Predecessors | Complete | Planned start | Planned finish | Resources | Cost | Actual cost | Planned FinishUDF | LOE Divider | LOE Multiplier | Calculated Remaining Total Cost | MONTHLY EV COST | RESP - Responsibility | STRT%COMP for CM EVM | FNSH%COMP for CM EVM | EVMS Reporting Codes | CAM RESPONSIBLE | CR 07-027 | Milestone Level | CR 08-029 | CR 08-058 | Remaining Material Cost Based on % Compl | Claimed Material Cost Based on % Complet | Initial Claimed Material Calc | Claimed Material Divider | ReBaseline Actuals Adjustment | CR 07-003 | ACT BRIDGING FY SPLIT | WBS ASSIGNMENT | EXPNS ACT BRIDGING FY SPLIT | CR 09-001 |
| --- | --- | --- | --- | --- | --- | --- | --- | --- | --- | --- | --- | --- | --- | --- | --- | --- | --- | --- | --- | --- | --- | --- | --- | --- | --- | --- | --- | --- | --- | --- | --- | --- | --- | --- | --- | --- | --- |
|  | 7 | **1.2.1.4.4.7 INSTALLATION** |  |  |  |  |  |  |  |  |  |  |  |  |  |  |  |  |  |  |  |  |  |  |  |  |  |  |  |  |  |  |  |  |  |  |  |
|  | 5 | **1.2.1.4.5 ARC 10 & HALL D BEAMLINE** |  |  | 2006-10-02 | 2013-08-30 |  |  |  |  |  |  |  |  |  |  |  |  |  |  |  |  |  |  |  |  |  |  |  |  |  |  |  |  |  |  |  |
|  | 1 | **1.2.1.4.5.1 DIPOLES** |  |  | 2006-10-02 | 2013-08-30 |  |  |  |  |  |  |  |  |  |  |  |  |  |  |  |  |  |  |  |  |  |  |  |  |  |  |  |  |  |  |  |
| 121451007LOE |  | FY07 Management of ARC 10 and Hall D (DIPOLES) |  | 247d | 2006-10-02 A | 2007-09-28 A | 9-070M | 100% |  |  | SCIENTIST [139.2 h]; SUPPLIES & MATERIALS; MECH ENG [156.6 h]; MECH TECH [69.6 h] | 41,767.61 | 21,127.61 | 2007-09-28 | 100 | 100 | 0 | 41767.607284 | WINES R | 1 | 1 | N/A | MIKE B |  |  |  |  |  |  |  |  |  |  |  |  |  |  |
| 121451020 |  | Develop Design of ARC 10 4m Dipole (DIPOLES) |  | 198d | 2006-10-02 A | 2007-07-20 A | 9-070M | 100% |  |  | MECH ENG [208.8 h]; MECH DES [348 h] | 28,168.99 | 28,168.99 | 2007-02-15 |  |  | 0 | 28322.328 | WINES R | 1 | 1 | N/A | MIKE B | 07-027 |  |  |  |  |  |  |  |  |  |  |  |  |  |
| 121451025 |  | Preliminary Design & Safety Review of General Dipoles |  | 19d | 2007-01-29 A | 2007-02-23 A | 121451020 FS-20d | 100% |  |  | MECH DES [34.8 h]; MECH ENG [34.8 h] | 3,691.93 | 3,691.93 | 2007-02-15 |  |  | 0 | 3691.932 | WINES R | 1 | 1 | N/A | MIKE B |  |  |  |  |  |  |  |  |  |  |  |  |  |  |
| 121451025M |  | General Dipole Design & Safety Review Completed | milestone | 0d | 2007-02-23 A | 2007-02-23 A | 121451025 | 100% | 2007-02-15 | 2007-02-15 |  |  |  | 2007-02-15 |  |  |  | 0 | WINES R | 1 | 1 | N/A | MIKE B |  | 5 |  |  |  |  |  |  |  |  |  |  |  |  |
| 121451030M |  | Finish Detailed Design of ARC 10 4m Dipole (DIPOLES) | milestone | 0d | 2007-07-20 A | 2007-07-20 A | 121451025M FS+50d, 121451020 FS+50d | 100% | 2007-04-27 | 2007-04-27 |  |  |  | 2007-02-15 |  |  |  | 0 | WINES R | 1 | 1 | N/A | MIKE B | 07-027 | 5 |  |  |  |  |  |  |  |  |  |  |  |  |
| 121451035 |  | Detailed Dsgn of 2m First bend Dipole (ARC 10/H-D Dipoles)++ |  | 257d | 2007-08-15 A | 2008-08-27 A | 121451030M, 9-080M | 100% |  |  | MECH DES [520 h]; MECH ENG [280 h] | 39,253.47 | 39,253.47 |  |  |  | 0 | 39404.8 | BEVINS M | 1 | 1 | N/A | MIKE B |  |  |  |  |  |  |  |  |  |  |  |  |  |  |
| 121451908LOE |  | FY08 Mngmnt of ARC 10 & H-D (ARC 10/H-D Dipoles) |  | 248d | 2007-10-01 A | 2008-09-30 A | 121451007LOE | 100% |  |  | SUPPLIES & MATERIALS; MECH ENG [160 h]; MECH TECH [200 h]; SR STAFF [280 h]; SCIENTIST [160 h] | 73,701.93 | 55,602.4 |  | 100 | 100 | 0 | 73701.926 | BEVINS M | 1 | 1 | N/A | MIKE B |  |  |  |  |  |  |  |  |  |  |  |  |  |  |
| 121451040 |  | Modify Alignment Fixture (ARC 10/H-D Dipoles) |  | 27d | 2007-12-10 A | 2008-01-25 A | 9-080M | 100% |  |  |  |  |  |  |  |  |  | 0 | BEVINS M | 1 | 1 | N/A | MIKE B |  |  |  |  |  |  |  |  |  |  |  |  |  |  |
| 121451909LOE |  | FY09 Mngmnt of ARC 10 & H-D (ARC 10/H-D Dipoles) |  | 248d | 2008-10-01 A | 2009-09-30 A | 121451908LOE | 100% |  |  | SCIENTIST [120 h]; SR STAFF [280 h] | 36,506.4 | 36,506.4 |  | 100 | 100 | 0 | 36506.4 | BEVINS M | 1 | 1 | E | MIKE B |  |  |  |  |  |  |  |  |  |  |  |  |  |  |
| 13451055XD |  | Prcrmnt Prep of 4m Dipoles (ARC10/H-D Dipoles) |  | 57d | 2008-10-01 A | 2008-12-22 A | 121451030M, 9-090M | 100% |  |  | MECH ENG [42.91 h]; MECH DES [28.61 h] | 3,992.35 | 3,992.35 |  |  |  | 0 | 3992.3495 | BEVINS M | 1 | 1 | H | MIKE B |  |  | 08-029 | 08-058 |  |  |  |  |  |  |  |  |  |  |
| 13451909LOEXD |  | FY09 Mngmnt & Oversight (ARC10/H-D Dipoles) |  | 59d | 2008-10-01 A | 2008-12-24 A | 121451908LOE | 100% |  |  | SR STAFF [47.58 h]; TRAVEL | 6,580.27 | 4,893.13 |  | 100 | 100 | 0 | 6580.263062 | BEVINS M | 1 | 1 | E | MIKE B |  |  |  | 08-058 |  |  |  |  |  |  |  |  |  |  |
| 121451060 |  | Re-Baseline Actuals Adjustment |  | 1d | 2013-08-30 A | 2013-08-30 A |  | 100% | 2013-09-03 | 2013-09-03 | PROCUREMENT>$50K 69 NO ESCALATION | 51,885.59 |  |  |  |  |  | 51885.59 |  |  |  |  |  |  |  |  |  | 0 | 51885.59 | 5188559 | 100 | ADJ |  |  |  |  |  |
|  | 2 | **1.2.1.4.5.2 QUADRUPOLES** |  |  | 2006-10-09 | 2013-08-30 |  |  |  |  |  |  |  |  |  |  |  |  |  |  |  |  |  |  |  |  |  |  |  |  |  |  |  |  |  |  |  |
| 121452005 |  | Develop Preliminary Design of New Quadrupoles |  | 141d | 2006-10-09 A | 2007-05-07 A | 9-070M FS+44d | 100% |  |  | MECH DES [208.8 h]; MECH ENG [208.8 h] | 22,139.27 | 22,139.27 | 2007-05-17 |  |  | 0 | 22130.939782 | WINES R | 1 | 1 | N/A | MIKE B |  |  |  |  |  |  |  |  |  |  |  |  |  |  |
| 121452010 |  | Preliminary Design & Safety Review of Quads |  | 37d | 2007-03-16 A | 2007-05-07 A | 121452005 FS-20d | 100% |  |  | MECH DES [34.8 h]; MECH ENG [34.8 h] | 3,684.11 | 3,684.11 | 2007-05-17 |  |  | 0 | 3680.796 | WINES R | 1 | 1 | N/A | MIKE B |  |  |  |  |  |  |  |  |  |  |  |  |  |  |
| 121452010M |  | Preliminary Quad Design & Safety Review Completed | milestone | 0d | 2007-05-07 A | 2007-05-07 A | 121452010, 121452005 | 100% | 2007-05-17 | 2007-05-17 |  |  |  | 2007-05-17 |  |  |  | 0 | WINES R | 1 | 1 | N/A | MIKE B |  | 5 |  |  |  |  |  |  |  |  |  |  |  |  |
| 121452015 |  | Develop Detailed Design of New Quadrupoles (QUAD POLES) |  | 112d | 2007-05-14 A | 2007-10-19 A | 121452010M | 100% |  |  | MECH ENG [174 h]; MECH DES [417.6 h] | 28,174.43 | 28,174.43 | 2007-09-25 |  |  | 0 | 28099.4456 | WINES R | 1 | 1 | N/A | MIKE B |  |  |  |  |  |  |  |  |  |  |  |  |  |  |
| 121452020M |  | New Quad Designs Complete (QUAD POLES) | milestone | 0d | 2007-10-19 A | 2007-10-19 A | 121452015 | 100% | 2007-11-19 | 2007-11-19 |  |  |  | 2007-09-25 |  |  |  | 0 | WINES R | 1 | 1 | N/A | MIKE B |  | 5 |  |  |  |  |  |  |  |  |  |  |  |  |
| 13452025X |  | Prcrmnt Prep for Quads (ARC 10/H-D Q-POLES) |  | 58d | 2008-10-01 A | 2008-12-23 A | 121452020M, 9-090M | 100% |  |  | MECH DES [51.87 h]; MECH ENG [51.87 h] | 5,583.8 | 5,583.8 |  |  |  | 0 | 5583.8055 | BEVINS M | 1 | 1 | H | MIKE B |  |  | 08-029 | 08-058 |  |  |  |  |  |  |  |  |  |  |
| 121452025 |  | Re-Baseline Actuals Adjustment |  | 1d | 2013-08-30 A | 2013-08-30 A |  | 100% | 2013-09-03 | 2013-09-03 | PROCUREMENT>$50K 69 NO ESCALATION | 108,652.09 |  |  |  |  |  | 108652.09 |  |  |  |  |  |  |  |  |  | 0 | 108652.09 | 10865209 | 100 | ADJ |  |  |  |  |  |
|  | 3 | **1.2.1.4.5.3 CORRECTORS** |  |  |  |  |  |  |  |  |  |  |  |  |  |  |  |  |  |  |  |  |  |  |  |  |  |  |  |  |  |  |  |  |  |  |  |
|  | 4 | **1.2.1.4.5.4 STANDS** |  |  | 2006-12-07 | 2013-08-30 |  |  |  |  |  |  |  |  |  |  |  |  |  |  |  |  |  |  |  |  |  |  |  |  |  |  |  |  |  |  |  |
| 121454005 |  | Develop Preliminary Design of Arc 10 and Hall D Layout (STANDS) |  | 99d | 2006-12-07 A | 2007-05-04 A | 9-070M FS+44d | 100% |  |  | MECH DES [417.6 h]; MECH ENG [208.8 h] | 31,359.19 | 31,359.19 | 2007-05-17 |  |  | 0 | 31348.320873 | BEVINS M | 1 | 1 | N/A | MIKE B |  |  |  |  |  |  |  |  |  | 07-003 |  |  |  |  |
| 121455000M |  | Begin Arc 10 and Hall D Girder Designs (GIRDERS) | milestone | 0d | 2007-02-20 A | 2007-02-20 A | 9-070M FS+98d | 100% | 2007-03-01 | 2007-03-01 |  |  |  | 2007-03-01 |  |  |  | 0 | BEVINS M | 1 | 1 | N/A | MIKE B |  | 9 |  |  |  |  |  |  |  | 07-003 |  |  |  |  |
| 121455005 |  | Preliminary Design Arc 10 & Hall D Quad Girders (GIRDERS) |  | 59d | 2007-02-20 A | 2007-05-11 A | 121455000M | 100% |  |  | MECH DES [137.6 h]; MECH ENG [48.8 h] | 9,078.67 | 9,078.67 | 2007-04-30 |  |  | 0 | 9080.049116 | BEVINS M | 1 | 1 | N/A | MIKE B |  |  |  |  |  |  |  |  |  | 07-003 |  |  |  |  |
| 121454010 |  | Preliminary Design & Safety Review of Arc 10 and Hall D Layout (STANDS) |  | 20d | 2007-04-09 A | 2007-05-04 A | 121454005 FS-20d | 100% |  |  | MECH DES [34.8 h]; MECH ENG [34.8 h] | 3,680.79 | 3,680.79 | 2007-05-17 |  |  | 0 | 3680.796 | BEVINS M | 1 | 1 | N/A | MIKE B |  |  |  |  |  |  |  |  |  | 07-003 |  |  |  |  |
| 121454010M |  | Preliminary Design & Safety Review of Arc 10 and Hall D Layout Completed | milestone | 0d | 2007-05-04 A | 2007-05-04 A | 121454005, 121454010, 121455005, 121456005 | 100% | 2007-05-17 | 2007-05-17 |  |  |  | 2007-05-17 |  |  |  | 0 | BEVINS M | 1 | 1 | N/A | MIKE B |  | 5 |  |  |  |  |  |  |  | 07-003 |  |  |  |  |
| 121455006 |  | FY07 Phase of Final Design Arc 10 & Hall D Quad Girders (GIRDERS) |  | 97d | 2007-05-14 A | 2007-09-28 A | 121454010M | 100% |  |  | MECH DES [280 h]; MECH ENG [160 h] | 21,486.18 | 21,486.18 | 2007-09-28 |  |  | 0 | 21456.740387 | BEVINS M | 1 | 1 | N/A | MIKE B |  |  |  |  |  |  |  |  |  | 07-003 |  |  |  |  |
| 121454015 |  | FY08 Detailed Dsgn of ARC 10 Stands++ |  | 295d | 2007-07-09 A | 2008-09-15 A | 9-080M | 100% | 2007-07-09 | 2008-09-12 | MECH ENG [1218.74 h]; MECH DES [1728.91 h]; PLABOR | 171,290.44 | 147,892.84 |  |  |  | 0 | 172208.5784 | BEVINS M | 1 | 1 | N/A | MIKE B |  |  |  |  |  |  |  |  |  |  | FY08-09 | 1.2.1.4.5.4 | EXP0809 | 09-001 |
| 121455010 |  | Final Dsgn H-D & Arc 10 Quad Girders (IARC 10/H-D Girders) |  | 170d | 2007-10-19 A | 2008-06-30 A | 121452020M, 121455006, 9-080M | 100% |  |  | MECH DES [480 h]; MECH ENG [240 h] | 35,232 | 35,232 |  |  |  | 0 | 35232 | BEVINS M | 1 | 1 | N/A | MIKE B |  |  |  |  |  |  |  |  |  |  |  |  |  |  |
| 121455015M |  | Finish H-D & Arc 10 Girders (IARC 10/H-D GIRDERS)++ | milestone | 0d | 2008-06-30 A | 2008-06-30 A | 121455010 | 100% | 2008-07-01 | 2008-07-01 |  |  |  |  |  |  |  | 0 | BEVINS M | 1 | 1 | M | MIKE B |  | 6 |  |  |  |  |  |  |  |  |  |  |  |  |
| 121454015a |  | FY09 Detailed Dsgn of ARC 10 Stands++ |  | 252d | 2008-09-16 A | 2009-09-21 A | 121454015 | 100% |  |  | PLABOR; MECH ENG [501.26 h]; MECH DES [711.09 h] | 73,004.45 | 63,074.27 |  |  |  | 0 | 73089.7662 | BEVINS M | 1 | 1 | N/A | MIKE B |  |  |  |  |  |  |  |  |  |  | FY08-09 | 1.2.1.4.5.4 | EXP0809 | 09-001 |
| 121454020 |  | Re-Baseline Actuals Adjustment |  | 1d | 2013-08-30 A | 2013-08-30 A |  | 100% | 2013-09-03 | 2013-09-03 | PROCUREMENT>$50K 69 NO ESCALATION | 174,877.85 |  |  |  |  |  | 174877.85 |  |  |  |  |  |  |  |  |  | 0 | 174877.85 | 17487785 | 100 | ADJ |  |  |  |  |  |

Notes:
- 121454015: Corrective Actions: Changed Purchased labor from $20K to $32K based on input from LH 050907 - / RKC / From MWiseman Rev B -2.xls
- 121454015a: Corrective Actions: Changed Purchased labor from $20K to $32K based on input from LH 050907 - / RKC / From MWiseman Rev B -2.xls

| ID | WBS | Activity | Type | Duration | Start | Finish | Predecessors | Complete | Planned start | Planned finish | Resources | Cost | Actual cost | Planned FinishUDF | Calculated Remaining Total Cost | MONTHLY EV COST | RESP - Responsibility | STRT%COMP for CM EVM | FNSH%COMP for CM EVM | EVMS Reporting Codes | CAM RESPONSIBLE | CR 07-027 | Remaining Material Cost Based on % Compl | Claimed Material Cost Based on % Complet | Initial Claimed Material Calc | Claimed Material Divider | ReBaseline Actuals Adjustment | LOE Divider | LOE Multiplier | CR 11-028 | Milestone Level | Ties | CR 08-058 |
| --- | --- | --- | --- | --- | --- | --- | --- | --- | --- | --- | --- | --- | --- | --- | --- | --- | --- | --- | --- | --- | --- | --- | --- | --- | --- | --- | --- | --- | --- | --- | --- | --- | --- |
|  | 5 | **1.2.1.4.5.5 GIRDERS** |  |  |  |  |  |  |  |  |  |  |  |  |  |  |  |  |  |  |  |  |  |  |  |  |  |  |  |  |  |  |  |
|  | 6 | **1.2.1.4.5.6 VACUUM** |  |  | 2007-03-02 | 2013-08-30 |  |  |  |  |  |  |  |  |  |  |  |  |  |  |  |  |  |  |  |  |  |  |  |  |  |  |  |
| 121456005 |  | PreliminaryDesign 4m Dipole Chambers (VACUUM) |  | 41d | 2007-03-02 A | 2007-04-27 A | 9-070M FS+120d | 100% |  |  | MECH ENG [20.88 h] | 1,292.4 | 1,292.4 | 2007-05-04 | 0 | 1295.3952 | BEVINS M | 1 | 1 | N/A | MIKE B |  |  |  |  |  |  |  |  |  |  |  |  |
| 121456010 |  | Detail Design 4m Dipole Chambers (VACUUM) |  | 118d | 2008-04-15 A | 2008-09-30 A | 121454010M | 100% |  |  | MECH ENG [34.8 h]; MECH DES [69.6 h] | 5,108.64 | 5,108.64 | 2007-07-16 | 0 | 5115.112195 | BEVINS M | 1 | 1 | H | MIKE B | 07-027 |  |  |  |  |  |  |  |  |  |  |  |
| 121456015 |  | Dsgn 2m Dipole Chamb for First bend (ARC 10 & H-D Vac)++ |  | 49d | 2008-07-23 A | 2008-09-30 A | 121456010, 9-080M FS+200d, 121451035 | 100% |  |  | MECH DES [80 h]; MECH ENG [40 h] | 5,872 | 5,872 |  | 0 | 5872 | BEVINS M | 1 | 1 | H | MIKE B | 07-027 |  |  |  |  |  |  |  |  |  |  |  |
| 121456999 |  | Pre-Constrctn Dsgn Review (ARC 10 & H-D)++ |  | 4d | 2009-09-22 A | 2009-09-25 A | 121451035, 9-080M FS-270d, 121451040, 121456015, 121454015a FS-200d, 121455015M | 100% |  |  |  |  |  |  |  | 0 | BEVINS M | 1 | 1 | Z | MIKE B | 07-027 |  |  |  |  |  |  |  |  |  |  |  |
| 121456020 |  | Re-Baseline Actuals Adjustment |  | 1d | 2013-08-30 A | 2013-08-30 A |  | 100% | 2013-09-03 | 2013-09-03 | PROCUREMENT>$50K 69 NO ESCALATION | 204.5 |  |  |  | 204.5 |  |  |  |  |  |  | 0 | 204.5 | 20450 | 100 | ADJ |  |  |  |  |  |  |
|  | 7 | **1.2.1.4.5.7 LCW & INSTRUMENT AIR** |  |  |  |  |  |  |  |  |  |  |  |  |  |  |  |  |  |  |  |  |  |  |  |  |  |  |  |  |  |  |  |
|  | 8 | **1.2.1.4.5.8 INSTALLATION** |  |  |  |  |  |  |  |  |  |  |  |  |  |  |  |  |  |  |  |  |  |  |  |  |  |  |  |  |  |  |  |
|  | 6 | **1.2.1.4.6 INJECTOR RECIRCULATION** |  |  |  |  |  |  |  |  |  |  |  |  |  |  |  |  |  |  |  |  |  |  |  |  |  |  |  |  |  |  |  |
|  | 1 | **1.2.1.4.6.1 DIPOLES** |  |  |  |  |  |  |  |  |  |  |  |  |  |  |  |  |  |  |  |  |  |  |  |  |  |  |  |  |  |  |  |
|  | 2 | **1.2.1.4.6.2 QUADRUPOLES** |  |  |  |  |  |  |  |  |  |  |  |  |  |  |  |  |  |  |  |  |  |  |  |  |  |  |  |  |  |  |  |
|  | 3 | **1.2.1.4.6.3 CORRECTORS** |  |  |  |  |  |  |  |  |  |  |  |  |  |  |  |  |  |  |  |  |  |  |  |  |  |  |  |  |  |  |  |
|  | 4 | **1.2.1.4.6.4 STANDS** |  |  |  |  |  |  |  |  |  |  |  |  |  |  |  |  |  |  |  |  |  |  |  |  |  |  |  |  |  |  |  |
|  | 5 | **1.2.1.4.6.5 GIRDERS** |  |  |  |  |  |  |  |  |  |  |  |  |  |  |  |  |  |  |  |  |  |  |  |  |  |  |  |  |  |  |  |
|  | 6 | **1.2.1.4.6.6 VACUUM** |  |  |  |  |  |  |  |  |  |  |  |  |  |  |  |  |  |  |  |  |  |  |  |  |  |  |  |  |  |  |  |
|  | 7 | **1.2.1.4.6.7 INSTALLATION** |  |  |  |  |  |  |  |  |  |  |  |  |  |  |  |  |  |  |  |  |  |  |  |  |  |  |  |  |  |  |  |
|  | 5 | **1.2.1.5 EXTRACTION** |  |  | 2006-10-02 | 2013-08-30 |  |  |  |  |  |  |  |  |  |  |  |  |  |  |  |  |  |  |  |  |  |  |  |  |  |  |  |
|  | 1 | **1.2.1.5.1 CAVITIES** |  |  | 2006-10-02 | 2013-08-30 |  |  |  |  |  |  |  |  |  |  |  |  |  |  |  |  |  |  |  |  |  |  |  |  |  |  |  |
| 12151007LOE |  | FY07 Management of Extraction WBS (CAVITIES) |  | 247d | 2006-10-02 A | 2007-09-28 A | 9-070M | 100% |  |  | SCIENTIST [382.8 h] | 24,132.04 | 24,132.04 | 2007-09-28 | 0 | 24132.035443 | SPATA M | 1 | 1 | N/A | MIKE S |  |  |  |  |  |  | 100 | 100 | 11-028 |  |  |  |
| 12151009 |  | Develop Design Package for Cavities (CAVITIES) |  | 55d | 2006-11-01 A | 2007-01-29 A | 9-070M FS+22d | 100% |  |  | MECH ENG [83.52 h]; ELEC ENG [83.52 h] | 10,676.37 | 10,676.37 | 2006-12-07 | 0 | 10676.3616 | SPATA M | 1 | 1 | N/A | MIKE S |  |  |  |  |  |  |  |  |  |  |  |  |
| 12151010 |  | Design & Safety Review for Cavity Package (CAVITIES) |  | 1d | 2007-01-30 A | 2007-01-30 A | 12151009 | 100% |  |  | MECH ENG [6.96 h]; ELEC ENG [6.96 h] | 889.7 | 889.7 | 2006-12-08 | 0 | 889.6968 | SPATA M | 1 | 1 | N/A | MIKE S |  |  |  |  |  |  |  |  |  |  |  |  |
| 12151015 |  | Post-review development of Design Package for Cavities (CAVITIES) |  | 60d | 2007-07-02 A | 2007-09-25 A | 12151010 | 100% |  |  | SKLLD TRADE [34.8 h]; MECH ENG [13.92 h]; ELEC ENG [13.92 h] | 2,668.9 | 2,668.9 | 2006-12-22 | 0 | 2818.5216 | SPATA M | 1 | 1 | N/A | MIKE S | 07-027 |  |  |  |  |  |  |  |  |  |  |  |
| 12151020M |  | Finish Design of RF Cavities (CAVITIES) | milestone | 0d | 2007-09-25 A | 2007-09-25 A | 12151015 | 100% | 2007-10-25 | 2007-10-25 |  |  |  | 2006-12-22 |  | 0 | SPATA M | 1 | 1 | N/A | MIKE S |  |  |  |  |  |  |  |  |  | 5 | Spata |  |
| 12151908LOE |  | FY08 Mngmnt of Extraction WBS |  | 248d | 2007-10-01 A | 2008-09-30 A | 12151007LOE | 100% |  |  | SCIENTIST [616 h] | 38,358.32 | 38,358.32 |  | 0 | 38358.32 | SPATA M | 1 | 1 | N/A | MIKE S |  |  |  |  |  |  | 100 | 100 | 11-028 |  | Spata |  |
| 1351909LOEX |  | FY09 Mngmnt Oversight (Cavities) |  | 59d | 2008-10-01 A | 2008-12-24 A | 12151908LOE, 9-090M | 100% |  |  | SCIENTIST [132.27 h]; TRAVEL | 9,386.3 | 8,499.67 |  | 0 | 9386.299318 | SPATA M | 1 | 1 | E | MIKE S |  |  |  |  |  |  | 100 | 100 |  |  |  | 08-058 |
| 12151025 |  | Re-Baseline Actuals Adjustment |  | 1d | 2013-08-30 A | 2013-08-30 A |  | 100% | 2013-09-03 | 2013-09-03 | PROCUREMENT>$50K 69 NO ESCALATION | -23,596.84 |  |  |  |  |  |  |  |  |  |  |  |  |  | 100 | ADJ |  |  |  |  |  |  |

Notes:
- 12151908LOE: Entry Criteria: Ext Pred: / 12151025LOE

| ID | WBS | Activity | Type | Duration | Start | Finish | Predecessors | Complete | Planned start | Planned finish | Resources | Cost | Actual cost | Planned FinishUDF | Calculated Remaining Total Cost | MONTHLY EV COST | RESP - Responsibility | STRT%COMP for CM EVM | FNSH%COMP for CM EVM | EVMS Reporting Codes | CAM RESPONSIBLE | CR 07-027 | Milestone Level | Claimed Material Divider | ReBaseline Actuals Adjustment | Ties | LOE Divider | LOE Multiplier | CR 08-058 | CR 11-028 | Remaining Material Cost Based on % Compl | Claimed Material Cost Based on % Complet | Initial Claimed Material Calc | CR 09-012 |
| --- | --- | --- | --- | --- | --- | --- | --- | --- | --- | --- | --- | --- | --- | --- | --- | --- | --- | --- | --- | --- | --- | --- | --- | --- | --- | --- | --- | --- | --- | --- | --- | --- | --- | --- |
|  | 2 | **1.2.1.5.2 RF COMPONENTS** |  |  | 2007-03-02 | 2013-08-30 |  |  |  |  |  |  |  |  |  |  |  |  |  |  |  |  |  |  |  |  |  |  |  |  |  |  |  |  |
| 12152005 |  | Develop design package for RF Components (RF COMPON) |  | 60d | 2007-03-02 A | 2007-05-24 A | 9-070M FS+88d | 100% |  |  | ELEC DES [55.68 h]; ELEC ENG [83.52 h] | 7,808.22 | 7,808.22 | 2007-03-28 | 0 | 8022.6528 | SPATA M | 1 | 1 | N/A | MIKE S |  |  |  |  |  |  |  |  |  |  |  |  |  |
| 12152010 |  | Design & Safety Review for RF Components (RF COMPON) |  | 1d | 2007-05-24 A | 2007-05-24 A | 12152005 | 100% |  |  | ELEC ENG [6.96 h]; ELEC DES [6.96 h] | 745.42 | 745.42 | 2007-03-29 | 0 | 772.908 | SPATA M | 1 | 1 | N/A | MIKE S |  |  |  |  |  |  |  |  |  |  |  |  |  |
| 12152015 |  | Post-review development of Design Package for RF Components (RF COMPON) |  | 14d | 2007-09-03 A | 2007-09-21 A | 12152010 | 100% | 2007-09-04 | 2007-09-21 | ELEC DES [6.96 h]; ELEC ENG [13.92 h] | 1,140.11 | 1,140.11 | 2007-04-12 | 0 | 1181.2077 | SPATA M | 1 | 1 | N/A | MIKE S | 07-027 |  |  |  |  |  |  |  |  |  |  |  |  |
| 12152025 |  | Continue Dsgn Package for RF Compnts (RF COMPON) |  | 10d | 2007-09-17 A | 2007-09-28 A | 9-080M, 12152015 | 100% |  |  | ELEC DES [80 h]; ELEC ENG [80 h] | 8,279.42 | 8,279.42 |  | 0 | 8543.2 | SPATA M | 1 | 1 | N/A | MIKE S |  |  |  |  |  |  |  |  |  |  |  |  |  |
| 12152030M |  | Comp Dsgn for RF Components++ | milestone | 0d | 2007-09-28 A | 2007-09-28 A | 12152025 | 100% | 2007-11-09 | 2007-11-09 |  |  |  |  |  | 0 | SPATA M | 1 | 1 | N/A | MIKE S |  | 6 |  |  |  |  |  |  |  |  |  |  |  |
| 12152035 |  | Re-Baseline Actuals Adjustment |  | 1d | 2013-08-30 A | 2013-08-30 A |  | 100% | 2013-09-03 | 2013-09-03 | PROCUREMENT>$50K 69 NO ESCALATION | -16,739.32 |  |  |  |  |  |  |  |  |  |  |  | 100 | ADJ |  |  |  |  |  |  |  |  |  |
|  | 3 | **1.2.1.5.3 RESONANCE CONTROL** |  |  | 2007-03-07 | 2013-08-30 |  |  |  |  |  |  |  |  |  |  |  |  |  |  |  |  |  |  |  |  |  |  |  |  |  |  |  |  |
| 12153005 |  | Determine and checkout LCW capacity (RESON CNTRL) |  | 1d | 2007-03-07 A | 2007-03-07 A | 9-070M | 100% |  |  | PLANT ENG [17.4 h] | 1,088.2 | 1,088.2 | 2006-10-06 | 0 | 1088.196 | SPATA M | 1 | 1 | N/A | MIKE S |  |  |  |  |  |  |  |  |  |  |  |  |  |
| 12153010 |  | Develop Design Package for Resonance Control (RESON CNTRL) |  | 162d | 2007-03-08 A | 2007-10-24 A | 9-070M | 100% |  |  | ELEC DES [104.4 h]; ELEC TECH [62.64 h]; MECH DES [48.72 h]; ELEC ENG [104.4 h] | 15,586.35 | 15,586.35 | 2006-11-10 | 0 | 16347.9264 | SPATA M | 1 | 1 | N/A | MIKE S |  |  |  |  |  |  |  |  |  |  |  |  |  |
| 12153015 |  | Design & Safety Review for Resonance Control (RESON CNTRL) |  | 1d | 2007-10-25 A | 2007-10-25 A | 12153005, 12153010 FS+3d | 100% |  |  | MECH DES [6.96 h]; ELEC ENG [6.96 h]; ELEC DES [6.96 h] | 1,038.92 | 1,038.92 | 2006-11-13 | 0 | 1081.4448 | SPATA M | 1 | 1 | N/A | MIKE S | 07-027 |  |  |  |  |  |  |  |  |  |  |  |  |
| 12153020 |  | Post-review development of Design Package for Resonance Control (RESON CNTRL) |  | 24d | 2007-10-26 A | 2007-11-30 A | 12153015 | 100% |  |  | MECH DES [13.92 h]; ELEC ENG [27.84 h]; ELEC DES [27.84 h]; ELEC TECH [6.96 h] | 3,835.3 | 3,835.3 | 2006-11-29 | 0 | 3996.9888 | SPATA M | 1 | 1 | N/A | MIKE S | 07-027 |  |  |  |  |  |  |  |  |  |  |  |  |
| 12153025M |  | Finish Resonance Control Design (RESON CNTRL) | milestone | 0d | 2007-11-30 A | 2007-11-30 A | 12153020 | 100% | 2007-12-14 | 2007-12-14 |  |  |  | 2006-11-29 |  | 0 | SPATA M | 1 | 1 | N/A | MIKE S |  | 5 |  |  | Spata |  |  |  |  |  |  |  |  |
| 12153025 |  | Re-Baseline Actuals Adjustment |  | 1d | 2013-08-30 A | 2013-08-30 A |  | 100% | 2013-09-03 | 2013-09-03 | PROCUREMENT>$50K 69 NO ESCALATION | -11,841.47 |  |  |  |  |  |  |  |  |  |  |  | 100 | ADJ |  |  |  |  |  |  |  |  |  |
|  | 4 | **1.2.1.5.4 LAMBERTSON** |  |  | 2007-04-09 | 2013-08-30 |  |  |  |  |  |  |  |  |  |  |  |  |  |  |  |  |  |  |  |  |  |  |  |  |  |  |  |  |
| 12154005 |  | Develop Design Package for Lambertson (LAMBERTSON) |  | 78d | 2007-04-09 A | 2007-07-27 A | 9-070M FS+108d | 100% |  |  | MECH DES [122 h]; MECH ENG [132.4 h] | 13,405.06 | 13,405.06 | 2007-05-23 | 0 | 13557.82672 | SPATA M | 1 | 1 | N/A | MIKE S |  |  |  |  |  |  |  |  |  |  |  |  |  |
| 12154010 |  | Design & Safety Review for Lambertson (LAMBERTSON) |  | 1d | 2007-05-24 A | 2007-05-24 A | 12154005 | 100% |  |  | MECH ENG [41.6 h]; MECH DES [146 h] | 8,965.44 | 8,965.44 | 2007-05-24 | 0 | 8965.444 | SPATA M | 1 | 1 | N/A | MIKE S |  |  |  |  |  |  |  |  |  |  |  |  |  |
| 12154015 |  | Post-review development of Design Package for Lambertson (LAMBERTSON) |  | 395d | 2007-07-16 A | 2009-02-20 A | 12154010 | 100% |  |  | MECH ENG [34.8 h]; MECH DES [45.24 h] | 4,087.28 | 4,087.28 | 2007-06-15 | 0 | 4137.3372 | SPATA M | 1 | 1 | N/A | MIKE S |  |  |  |  |  |  |  |  |  |  |  |  |  |
| 1354909LOEX |  | FY09 Engrng Oversight (LAMBERTSON) |  | 59d | 2008-10-01 A | 2008-12-24 A | 9-090M | 100% |  |  | MECH ENG [19.03 h]; TRAVEL | 1,974.27 | 1,214.3 |  | 0 | 1974.278012 | SPATA M | 1 | 1 | E | MIKE S |  |  |  |  |  | 100 | 100 | 08-058 | 11-028 |  |  |  |  |
| 12154020M |  | Finished Lambertson Design (LAMBERTSON) | milestone | 0d | 2009-02-20 A | 2009-02-20 A | 12154015 | 100% | 2009-03-13 | 2009-03-13 |  |  |  | 2007-06-15 |  | 0 | SPATA M | 1 | 1 | M | MIKE S |  | 5 |  |  | Spata |  |  |  |  |  |  |  |  |
| 12154025 |  | Re-Baseline Actuals Adjustment |  | 1d | 2013-08-30 A | 2013-08-30 A |  | 100% | 2013-09-03 | 2013-09-03 | PROCUREMENT>$50K 69 NO ESCALATION | 12,642.91 |  |  |  | 12642.91 |  |  |  |  |  |  |  | 100 | ADJ |  |  |  |  |  | 0 | 12642.91 | 1264291 |  |
|  | 5 | **1.2.1.5.5 SEPTA & DIPOLES** |  |  | 2007-02-13 | 2013-08-30 |  |  |  |  |  |  |  |  |  |  |  |  |  |  |  |  |  |  |  |  |  |  |  |  |  |  |  |  |
| 12155005 |  | Develop Design Package for Septa and Dipoles (SEPTA/DIPOLES) |  | 137d | 2007-02-13 A | 2007-08-27 A | 9-070M FS+87d | 100% |  |  | MECH ENG [215.76 h] | 13,238.29 | 13,238.29 | 2007-05-30 | 0 | 13359.168768 | SPATA M | 1 | 1 | N/A | MIKE S |  |  |  |  |  |  |  |  |  |  |  |  |  |
| 12155006 |  | Preliminary Design & Safety Review for Septa and Dipoles (SEPTA/DIPOLES) |  | 1d | 2007-05-24 A | 2007-05-24 A | 12155005 | 100% |  |  | MECH ENG [6.96 h] | 431.8 | 431.8 | 2007-05-31 | 0 | 431.7984 | SPATA M | 1 | 1 | N/A | MIKE S |  |  |  |  |  |  |  |  |  |  |  |  |  |
| 12155007 |  | Post-review development of Design Package for Septa and dipoles (SEPTA/DIPOLES) |  | 31d | 2007-07-16 A | 2007-08-27 A | 12155006 | 100% |  |  | MECH ENG [20.88 h] | 1,251.34 | 1,251.34 | 2007-06-14 | 0 | 1295.3952 | SPATA M | 1 | 1 | N/A | MIKE S |  |  |  |  |  |  |  |  |  |  |  |  |  |
| 12155908LOE |  | FY08 Oversee Dsgn Package for Septa & Dipoles |  | 248d | 2007-10-01 A | 2008-09-30 A | 9-080M | 100% |  |  | MECH ENG [72 h] | 4,452.48 | 4,452.48 |  | 0 | 4452.48 | SPATA M | 1 | 1 | N/A | MIKE S |  |  |  |  | Spata | 100 | 100 |  |  |  |  |  |  |
| 12155035 |  | Dsgn Septa & Dipoles |  | 316d | 2008-01-14 A | 2009-04-20 A | 12155007, 9-080M | 100% |  |  | MECH ENG [136 h]; MECH DES [92 h] | 12,485.07 | 12,485.07 |  | 0 | 12318.4 | SPATA M | 1 | 1 | N/A | MIKE S |  |  |  |  |  |  |  |  |  |  |  |  | 09-012 |
| 12155045 |  | Post-Review Development of Dsgn Package for Septa & Dipoles |  | 7d | 2008-05-20 A | 2008-05-29 A | 12155040 | 100% |  |  | MECH DES [68 h]; MECH ENG [76 h] | 7,588.48 | 7,588.48 |  | 0 | 7588.48 | SPATA M | 1 | 1 | H | MIKE S |  |  |  |  |  |  |  |  |  |  |  |  | 09-012 |
| 12155040 |  | Prelim Dsgn Review for Septa & Dipoles |  | 4d | 2008-05-27 A | 2008-05-30 A | 12155035 | 100% |  |  | MECH ENG [8 h]; MECH DES [8 h] | 834.56 | 834.56 |  | 0 | 834.56 | SPATA M | 1 | 1 | H | MIKE S |  |  |  |  |  |  |  |  |  |  |  |  |  |
| 12155050M |  | End of Extraction Septa & Dipole PED Effort | milestone | 0d | 2009-04-20 A | 2009-04-20 A | 12155035, 12155045 | 100% | 2009-05-29 | 2009-05-29 |  |  |  |  |  | 0 | SPATA M | 1 | 1 | M | MIKE S |  | 6 |  |  | Spata |  |  |  |  |  |  |  |  |
| 12155055 |  | Re-Baseline Actuals Adjustment |  | 1d | 2013-08-30 A | 2013-08-30 A |  | 100% | 2013-09-03 | 2013-09-03 | PROCUREMENT>$50K 69 NO ESCALATION | 29,184.73 |  |  |  | 29184.73 |  |  |  |  |  |  |  | 100 | ADJ |  |  |  |  |  | 0 | 29184.73 | 2918473 |  |

| ID | WBS | Activity | Type | Duration | Start | Finish | Predecessors | Complete | Planned start | Planned finish | Resources | Cost | Actual cost | Planned FinishUDF | Calculated Remaining Total Cost | MONTHLY EV COST | RESP - Responsibility | STRT%COMP for CM EVM | FNSH%COMP for CM EVM | EVMS Reporting Codes | CAM RESPONSIBLE | CR 07-027 | Ties | CR 08-003 | WBS ASSIGNMENT | EXPNS ACT BRIDGING FY SPLIT | CR 09-001 | ACT BRIDGING FY SPLIT | Milestone Level | Remaining Material Cost Based on % Compl | Claimed Material Cost Based on % Complet | Initial Claimed Material Calc | Claimed Material Divider | ReBaseline Actuals Adjustment | LOE Divider | LOE Multiplier | CR 09-012 | Profile change | CR 08-058 |
| --- | --- | --- | --- | --- | --- | --- | --- | --- | --- | --- | --- | --- | --- | --- | --- | --- | --- | --- | --- | --- | --- | --- | --- | --- | --- | --- | --- | --- | --- | --- | --- | --- | --- | --- | --- | --- | --- | --- | --- |
|  | 6 | **1.2.1.5.6 STANDS** |  |  | 2007-01-10 | 2013-08-30 |  |  |  |  |  |  |  |  |  |  |  |  |  |  |  |  |  |  |  |  |  |  |  |  |  |  |  |  |  |  |  |  |  |
| 12156005 |  | Develop Design Package for Stands (STANDS) |  | 180d | 2007-01-10 A | 2007-09-25 A | 9-070M FS+22d | 100% |  |  | MECH DES [320.16 h]; MECH ENG [139.2 h] | 22,313.21 | 22,313.21 | 2007-03-06 | 0 | 22789.6848 | SPATA M | 1 | 1 | N/A | MIKE S |  |  |  |  |  |  |  |  |  |  |  |  |  |  |  |  |  |  |
| 12156010 |  | Preliminary Design & Safety Review for Stands (STANDS) |  | 1d | 2007-05-24 A | 2007-05-24 A | 12156005 | 100% |  |  | MECH ENG [6.96 h] | 431.8 | 431.8 | 2007-03-07 | 0 | 429.8496 | SPATA M | 1 | 1 | N/A | MIKE S |  |  |  |  |  |  |  |  |  |  |  |  |  |  |  |  |  |  |
| 12156000 |  | FY08 Expenses |  | 247d | 2007-10-01 A | 2008-09-30 A | 9-080M | 100% | 2007-10-01 | 2008-09-29 | TRAVEL; SUPPLIES & MATERIALS | 10,927.82 |  |  | 0 | 10927.821 | SPATA M | 1 | 1 | N/A | MIKE S | 07-027 | Spata | 08-003 |  |  |  |  |  |  |  |  |  |  |  |  |  |  |  |
| 12156015 |  | Post-review development of Design Package for Stands (STANDS) |  | 20d | 2007-11-01 A | 2007-11-30 A | 12156010 | 100% |  |  | MECH DES [56 h]; MECH ENG [34.8 h] | 4,530.91 | 4,530.91 | 2007-04-04 | 0 | 4628.1496 | SPATA M | 1 | 1 | N/A | MIKE S |  |  |  |  |  |  |  |  |  |  |  |  |  |  |  |  |  |  |
| 12156030 |  | FY08 Develop Dsgn Package for Stands |  | 175d | 2007-11-26 A | 2008-08-11 A | 9-080M, 12156015 | 100% |  |  | MECH DES [1047.2 h]; MECH ENG [440.8 h] | 71,744.13 | 71,744.13 |  | 0 | 71745.8704 | SPATA M | 1 | 1 | N/A | MIKE S | 07-027 |  |  | 1.2.1.5.6 | EXP0809 | 09-001 |  |  |  |  |  |  |  |  |  |  |  |  |
| 12156030a |  | FY09 Develop Dsgn Package for Stands |  | 18d | 2008-08-12 A | 2008-09-05 A | 12156030 | 100% |  |  | MECH DES [472.89 h]; MECH ENG [199.11 h] | 32,401.33 | 32,401.33 |  | 0 | 33436.7067 | SPATA M | 1 | 1 | N/A | MIKE S | 07-027 |  |  | 1.2.1.5.6 | EXP0809 | 09-001 |  |  |  |  |  |  |  |  |  |  |  |  |
| 12156035 |  | Finalize Dsgn Package for Stands |  | 259d | 2008-09-08 A | 2009-09-22 A | 12156030a | 100% |  |  | MECH DES [320 h]; MECH ENG [200 h] | 26,736.37 | 26,736.37 |  | 0 | 26790.8 | SPATA M | 1 | 1 | H | MIKE S | 07-027 | Spata |  |  |  |  | FY08-09 |  |  |  |  |  |  |  |  |  |  |  |
| 12156002 |  | FY09 Expenses |  | 160d | 2008-11-03 A | 2009-06-29 A | 12156000 | 100% |  |  | TRAVEL; SUPPLIES & MATERIALS | 11,276.42 |  |  | 0 | 11276.41849 | SPATA M | 1 | 1 | H | MIKE S | 07-027 | Spata | 08-003 |  |  |  |  |  |  |  |  |  |  |  |  |  |  |  |
| 12156040M |  | Stands Dsgn Comp++ | milestone | 0d | 2009-09-22 A | 2009-09-22 A | 12156035 | 100% | 2009-10-22 | 2009-10-22 |  |  |  |  |  | 0 | SPATA M | 1 | 1 | M | MIKE S | 07-027 | Spata |  |  |  |  |  | 6 |  |  |  |  |  |  |  |  |  |  |
| 12156045 |  | Pre-Constrctn Dsgn Review for Extraction++ |  | 1d | 2009-09-23 A | 2009-09-23 A | 12152030M, 12155050M, 12153025M, 12154020M, 12156040M | 100% |  |  |  |  |  |  |  | 0 | SPATA M | 1 | 1 | Z | MIKE S | 07-027 | Spata |  |  |  |  |  |  |  |  |  |  |  |  |  |  |  |  |
| 12156050 |  | Re-Baseline Actuals Adjustment |  | 1d | 2013-08-30 A | 2013-08-30 A |  | 100% | 2013-09-03 | 2013-09-03 | PROCUREMENT>$50K 69 NO ESCALATION | 56,453.13 |  |  |  | 56453.13 |  |  |  |  |  |  |  |  |  |  |  |  |  | 0 | 56453.13 | 5645313 | 100 | ADJ |  |  |  |  |  |
|  | 6 | **1.2.1.6 INSTRUMENTATION, CONTROLS, & SAFETY SYSTEMS** |  |  | 2006-10-02 | 2013-08-30 |  |  |  |  |  |  |  |  |  |  |  |  |  |  |  |  |  |  |  |  |  |  |  |  |  |  |  |  |  |  |  |  |  |
|  | 1 | **1.2.1.6.1 BEAM DIAGNOSTICS** |  |  | 2006-10-02 | 2013-08-30 |  |  |  |  |  |  |  |  |  |  |  |  |  |  |  |  |  |  |  |  |  |  |  |  |  |  |  |  |  |  |  |  |  |
|  | 1 | **1.2.1.6.1.1 BPM's** |  |  | 2006-10-02 | 2013-08-30 |  |  |  |  |  |  |  |  |  |  |  |  |  |  |  |  |  |  |  |  |  |  |  |  |  |  |  |  |  |  |  |  |  |
| 121611007LOE |  | FY07 Management Effort (BPMs) |  | 247d | 2006-10-02 A | 2007-09-28 A | 9-070M | 100% |  |  | SR STAFF [69.6 h] | 6,933.1 | 6,933.1 | 2007-09-28 | 0 | 6933.0996 | GARZA O | 1 | 1 | N/A | MIKE S |  |  |  |  |  |  |  |  |  |  |  |  |  | 100 | 100 | 09-012 |  |  |
| 121611010 |  | Define & Package System Layout (BPMs) |  | 87.5d | 2006-10-16 A | 2007-02-28 A | 9-070M FS+44d | 100% |  |  | ELEC ENG [52.2 h]; SCIENTIST [52.4 h] | 6,812.41 | 6,812.41 | 2007-01-12 | 0 | 6812.41 | GARZA O | 1 | 1 | N/A | MIKE S |  |  |  |  |  |  |  |  |  |  |  |  |  |  |  |  |  |  |
| 121611015 |  | Design Top-Level System Layout (BPMs) |  | 39.5d | 2007-01-02 A | 2007-02-28 A | 121611010 | 100% |  |  | ELEC DES [121.8 h]; ELEC ENG [87 h]; SCIENTIST [34.8 h]; ELEC TECH [87 h] | 17,064 | 17,064 | 2007-02-14 | 0 | 17064.006 | GARZA O | 1 | 1 | N/A | MIKE S |  |  |  |  |  |  |  |  |  |  |  |  |  |  |  |  |  |  |
| 121611020 |  | Evaluate System Interface (BPMs) |  | 72.5d | 2007-02-13 A | 2007-05-25 A | 121611010 | 100% |  |  | COMP SCIENT [34.8 h] | 2,019.26 | 2,019.26 | 2007-02-14 | 0 | 2015.616 | GARZA O | 1 | 1 | N/A | MIKE S |  |  |  |  |  |  |  |  |  |  |  |  |  |  |  |  |  |  |
| 121611025 |  | Preliminary Design & Safety Review (BPMs) |  | 75d | 2007-02-15 A | 2007-06-01 A | 121611030M, 121611015, 121611020 | 100% |  |  | ELEC ENG [6.96 h] | 443.72 | 443.72 | 2007-02-15 | 0 | 459.8472 | GARZA O | 1 | 1 | N/A | MIKE S |  |  |  |  |  |  |  |  |  |  |  |  |  |  |  |  |  |  |
| 121611025M |  | Complete Preliminary Design & Safety Review (BPMs) | milestone | 0d | 2007-06-01 A | 2007-06-01 A | 121611025 | 100% | 2007-02-15 | 2007-02-15 |  |  |  | 2007-02-15 |  | 0 | GARZA O | 1 | 1 | N/A | MIKE S |  |  |  |  |  |  |  | 5 |  |  |  |  |  |  |  |  |  |  |
| 121611030M |  | Ready to Baseline (BPMs) | milestone | 0d | 2007-06-01 A | 2007-06-01 A | 121611020 | 100% | 2007-02-14 | 2007-02-14 |  |  |  | 2007-02-14 |  | 0 | GARZA O | 1 | 1 | N/A | MIKE S |  |  |  |  |  |  |  | 9 |  |  |  |  |  |  |  |  |  |  |
| 121611908LOE |  | FY08 Mngmnt Effort for BPMs |  | 248d | 2007-10-01 A | 2008-09-30 A | 9-080M | 100% |  |  | SR STAFF [80 h] | 7,972.8 | 7,972.8 |  | 0 | 7972.8 | GARZA O | 1 | 1 | N/A | MIKE S |  |  |  |  |  |  |  |  |  |  |  |  |  | 100 | 100 |  |  |  |
| 121611040 |  | FY08 Comp BPM Sys Dsgn |  | 159d | 2007-11-01 A | 2008-06-27 A | 121611007LOE, 9-080M, 121611025M | 100% | 2007-11-01 | 2008-06-26 | SCIENTIST [80 h]; ELEC ENG [180 h]; ELEC TECH [120 h]; COMP SCIENT [80 h] | 25,486 | 25,486 |  | 0 | 25486 | GARZA O | 1 | 1 | N/A | MIKE S |  |  |  |  |  |  |  |  |  |  |  |  |  |  |  |  |  |  |
| 121611041 |  | Pre-Constrctn Final Dsgn Review for BPM's |  | 21d | 2008-05-01 A | 2008-05-30 A | 121611040 | 100% |  |  | ELEC ENG [20 h] | 1,244.8 | 1,244.8 |  | 0 | 1244.8 | GARZA O | 1 | 1 | H | MIKE S | 07-027 |  |  |  |  |  |  |  |  |  |  |  |  |  |  |  | C |  |
| 121611045 |  | Compile Mech BPM Prcrmnt Packages |  | 21d | 2008-05-01 A | 2008-05-30 A | 121611041 FS+90d | 100% |  |  | TRAVEL; PROCUREMENT<$50K 60; ELEC ENG [80 h]; ELEC TECH [80 h]; SCIENTIST [40 h] | 18,901.51 | 10,584.4 |  | 0 | 18901.514 | GARZA O | 1 | 1 | H | MIKE S | 07-027 |  |  |  |  |  |  |  | 0 | 6191.4 | 619140 | 100 |  |  |  |  |  |  |
| 13611909LOEX |  | FY09 Mngmnt Effort for BPMs |  | 59d | 2008-10-01 A | 2008-12-24 A | 121612908LOE, 121611908LOE | 100% |  |  | SR STAFF [1.9 h] | 195.4 | 195.4 |  | 0 | 195.396 | GARZA O | 1 | 1 | E | MIKE S |  |  |  |  |  |  |  |  |  |  |  |  |  | 100 | 100 |  |  | 08-058 |
| 121611050 |  | Compile Elect BPM Prcrmnt Packages |  | 96d | 2009-05-15 A | 2009-09-30 A | 9-090M FS+120d, 121611041 | 100% |  |  | SCIENTIST [40 h]; TRAVEL; PROCUREMENT<$50K 60; ELEC ENG [120 h]; ELEC TECH [80 h] | 22,191.16 | 13,491.6 |  | 0 | 22191.159874 | GARZA O | 1 | 1 | H | MIKE S | 07-027 |  |  |  |  |  |  |  | 0 | 6388.91 | 638891 | 100 |  |  |  |  |  |  |
| 121611055M |  | BPM PED Comp++ | milestone | 0d | 2009-09-30 A | 2009-09-30 A | 121611050, 121611045 | 100% | 2009-10-29 | 2009-10-29 |  |  |  |  |  | 0 | GARZA O | 1 | 1 | M | MIKE S | 07-027 |  |  |  |  |  |  | 6 |  |  |  |  |  |  |  |  |  |  |
| 121611060 |  | Re-Baseline Actuals Adjustment |  | 1d | 2013-08-30 A | 2013-08-30 A |  | 100% | 2013-09-03 | 2013-09-03 | PROCUREMENT>$50K 69 NO ESCALATION | -47,841.98 |  |  |  |  |  |  |  |  |  |  |  |  |  |  |  |  |  |  |  |  | 100 | ADJ |  |  |  |  |  |

| ID | WBS | Activity | Type | Duration | Start | Finish | Predecessors | Complete | Planned start | Planned finish | Resources | Cost | Actual cost | Planned FinishUDF | LOE Divider | LOE Multiplier | Calculated Remaining Total Cost | MONTHLY EV COST | RESP - Responsibility | STRT%COMP for CM EVM | FNSH%COMP for CM EVM | EVMS Reporting Codes | CAM RESPONSIBLE | CR 09-012 | Milestone Level | Profile change | CR 08-058 | CR 07-027 | Remaining Material Cost Based on % Compl | Claimed Material Cost Based on % Complet | Initial Claimed Material Calc | Claimed Material Divider | ReBaseline Actuals Adjustment |
| --- | --- | --- | --- | --- | --- | --- | --- | --- | --- | --- | --- | --- | --- | --- | --- | --- | --- | --- | --- | --- | --- | --- | --- | --- | --- | --- | --- | --- | --- | --- | --- | --- | --- |
|  | 2 | **1.2.1.6.1.2 HARPS** |  |  | 2006-10-02 | 2013-08-30 |  |  |  |  |  |  |  |  |  |  |  |  |  |  |  |  |  |  |  |  |  |  |  |  |  |  |  |
| 121612007LOE |  | FY07 Management Effort Harps (HARPS) |  | 247d | 2006-10-02 A | 2007-09-28 A | 9-070M | 100% |  |  | SR STAFF [34.8 h] | 3,466.55 | 3,466.55 | 2007-09-28 | 100 | 100 | 0 | 3466.5498 | GARZA O | 1 | 1 | N/A | MIKE S | 09-012 |  |  |  |  |  |  |  |  |  |
| 121612010 |  | Design Top-Level System Layout (HARPS) |  | 73.5d | 2006-11-01 A | 2007-02-26 A | 9-070M | 100% |  |  | ELEC DES [34.8 h]; ELEC ENG [34.8 h] | 3,864.54 | 3,864.54 | 2006-11-01 |  |  | 0 | 3864.54 | GARZA O | 1 | 1 | N/A | MIKE S |  |  |  |  |  |  |  |  |  |  |
| 121612011 |  | Preliminary Design & Safety Review Harps (HARPS) |  | 82d | 2007-02-20 A | 2007-06-15 A | 121612010 FS+75d | 100% |  |  | ELEC ENG [6.96 h] | 441.91 | 441.91 | 2007-03-01 |  |  | 0 | 459.8472 | GARZA O | 1 | 1 | N/A | MIKE S |  |  |  |  |  |  |  |  |  |  |
| 121612015M |  | Complete Preliminary Design & Safety Review Harps (HARPS) | milestone | 0d | 2007-06-15 A | 2007-06-15 A | 121612011 | 100% | 2007-03-01 | 2007-03-01 |  |  |  | 2007-03-01 |  |  |  | 0 | GARZA O | 1 | 1 | N/A | MIKE S |  | 5 |  |  |  |  |  |  |  |  |
| 121612020M |  | Ready to baseline Harp WBS (HARPS) | milestone | 0d | 2007-06-15 A | 2007-06-15 A | 121612010 FS+76d | 100% | 2007-03-01 | 2007-03-01 |  |  |  | 2007-03-01 |  |  |  | 0 | GARZA O | 1 | 1 | N/A | MIKE S |  | 9 |  |  |  |  |  |  |  |  |
| 121612908LOE |  | FY08 Mngmnt Effort Harps |  | 248d | 2007-10-01 A | 2008-09-30 A | 121612007LOE | 100% |  |  | SR STAFF [40 h] | 3,986.4 | 3,986.4 |  | 100 | 100 | 0 | 3986.4 | GARZA O | 1 | 1 | N/A | MIKE S |  |  |  |  |  |  |  |  |  |  |
| 121612021 |  | FY08 Comp Harp Sys Dsgn |  | 61d | 2007-11-01 A | 2008-02-07 A | 9-080M, 121612015M, 121612020M | 100% |  |  |  |  |  |  |  |  |  | 0 | GARZA O | 1 | 1 | N/A | MIKE S |  |  |  |  |  |  |  |  |  |  |
| 121612022 |  | Pre-Constrctn Final Dsgn Review for Harps |  | 2.5d | 2008-02-08 A | 2008-02-12 A | 121612021 | 100% |  |  |  |  |  |  |  |  |  | 0 | GARZA O | 1 | 1 | N/A | MIKE S |  |  | C |  |  |  |  |  |  |  |
| 13612909LOEX |  | FY09 Mngmnt Effort for Harps |  | 59d | 2008-10-01 A | 2008-12-24 A | 121612908LOE | 100% |  |  | SR STAFF [7.61 h] | 782.61 | 782.61 |  | 100 | 100 | 0 | 782.6124 | GARZA O | 1 | 1 | E | MIKE S |  |  |  | 08-058 |  |  |  |  |  |  |
| 121612030 |  | Compile Harp Sys Elect Prcrmnt Packages+ |  | 83.5d | 2009-05-16 A | 2009-09-15 A | 9-090M FS+125d, 121612022 | 100% | 2009-05-18 | 2009-09-15 | ELEC TECH [20 h]; SCIENTIST [40 h]; ELEC ENG [20 h] | 4,658.4 | 4,658.4 |  |  |  | 0 | 4658.4 | GARZA O | 1 | 1 | H | MIKE S |  |  |  |  | 07-027 |  |  |  |  |  |
| 121612035 |  | Compile Harp Sys Mech Prcrmnt Packages+ |  | 83.5d | 2009-05-16 A | 2009-09-15 A | 121612022, 9-090M FS+125d | 100% | 2009-05-18 | 2009-09-15 | ELEC TECH [20 h]; ELEC ENG [20 h] | 2,088 | 2,088 |  |  |  | 0 | 2088 | GARZA O | 1 | 1 | H | MIKE S |  |  |  |  | 07-027 |  |  |  |  |  |
| 121612040 |  | Re-Baseline Actuals Adjustment |  | 1d | 2013-08-30 A | 2013-08-30 A |  | 100% | 2013-09-03 | 2013-09-03 | PROCUREMENT>$50K 69 NO ESCALATION | 3,744.22 |  |  |  |  |  | 3744.22 |  |  |  |  |  |  |  |  |  |  | 0 | 3744.22 | 374422 | 100 | ADJ |
|  | 3 | **1.2.1.6.1.3 VIEWERS** |  |  | 2006-10-02 | 2013-08-30 |  |  |  |  |  |  |  |  |  |  |  |  |  |  |  |  |  |  |  |  |  |  |  |  |  |  |  |
| 121613007LOE |  | FY07 Management Effort for Viewers (VIEWERS) |  | 247d | 2006-10-02 A | 2007-09-28 A | 9-070M | 100% |  |  | SR STAFF [34.8 h] | 3,466.55 | 3,466.55 | 2007-09-28 | 100 | 100 | 0 | 3466.5498 | GARZA O | 1 | 1 | N/A | MIKE S | 09-012 |  |  |  |  |  |  |  |  |  |
| 121613010 |  | Design Top-Level System Layout (VIEWERS) |  | 73.5d | 2006-11-01 A | 2007-02-26 A | 9-070M | 100% |  |  | ELEC DES [34.8 h]; ELEC ENG [34.8 h] | 3,864.54 | 3,864.54 | 2006-11-01 |  |  | 0 | 3864.54 | GARZA O | 1 | 1 | N/A | MIKE S |  |  |  |  |  |  |  |  |  |  |
| 121613011 |  | Preliminary Design & Safety Review Viewers (VIEWERS) |  | 82.5d | 2007-02-19 A | 2007-06-15 A | 121613010 FS+75d | 100% | 2007-02-20 | 2007-06-15 | ELEC ENG [6.96 h] | 442.02 | 442.02 | 2007-03-01 |  |  | 0 | 459.8472 | GARZA O | 1 | 1 | N/A | MIKE S |  |  |  |  |  |  |  |  |  |  |
| 121613015M |  | Complete Preliminary Design & Safety Review Viewers (VIEWERS) | milestone | 0d | 2007-06-15 A | 2007-06-15 A | 121613011 | 100% | 2007-03-01 | 2007-03-01 |  |  |  | 2007-03-01 |  |  |  | 0 | GARZA O | 1 | 1 | N/A | MIKE S |  | 5 |  |  |  |  |  |  |  |  |
| 121613020M |  | Ready to Baseline Viewers (VIEWERS) | milestone | 0d | 2007-06-15 A | 2007-06-15 A | 121614015M, 121613015M, 121613010 FS+76d | 100% | 2007-03-01 | 2007-03-01 |  |  |  | 2007-03-01 |  |  |  | 0 | GARZA O | 1 | 1 | N/A | MIKE S |  | 9 |  |  |  |  |  |  |  |  |
| 121613908LOE |  | FY08 Mngmnt Effort for Viewers |  | 248d | 2007-10-01 A | 2008-09-30 A | 121613007LOE, 9-080M | 100% |  |  | SR STAFF [40 h] | 3,986.4 | 3,986.4 |  | 100 | 100 | 0 | 3986.4 | GARZA O | 1 | 1 | N/A | MIKE S |  |  |  |  |  |  |  |  |  |  |
| 121613026 |  | FY08 Comp Viewer Sys Dsgn |  | 61d | 2007-11-01 A | 2008-02-07 A | 9-080M, 121613020M | 100% |  |  |  |  |  |  |  |  |  | 0 | GARZA O | 1 | 1 | N/A | MIKE S |  |  |  |  |  |  |  |  |  |  |
| 121613027 |  | Pre-Constrctn Final Dsgn Review for Viewers |  | 2.5d | 2008-02-08 A | 2008-02-12 A | 121613026 | 100% |  |  |  |  |  |  |  |  |  | 0 | GARZA O | 1 | 1 | N/A | MIKE S |  |  | C |  |  |  |  |  |  |  |
| 13613909LOEX |  | FY09 Mngmnt Effort for Viewer Syss |  | 59d | 2008-10-01 A | 2008-12-24 A | 121613908LOE | 100% |  |  | SR STAFF [7.61 h] | 782.61 | 782.61 |  | 100 | 100 | 0 | 782.6124 | GARZA O | 1 | 1 | E | MIKE S |  |  |  | 08-058 |  |  |  |  |  |  |
| 121613030 |  | Compile Viewer Sys Elect Prcrmnt Packages |  | 85d | 2009-05-15 A | 2009-09-15 A | 9-090M FS+120d, 121613027 | 100% |  |  | SCIENTIST [40 h]; ELEC ENG [20 h]; ELEC TECH [20 h] | 4,658.4 | 4,658.4 |  |  |  | 0 | 4658.4 | GARZA O | 1 | 1 | H | MIKE S |  |  |  |  | 07-027 |  |  |  |  |  |
| 121613035 |  | Compile Viewer Sys Mech Prcrmnt Packages |  | 85d | 2009-05-15 A | 2009-09-15 A | 9-090M FS+120d, 121613027 | 100% |  |  | ELEC TECH [20 h]; SUPPLIES & MATERIALS; ELEC ENG [20 h] | 3,184.76 | 2,088 |  |  |  | 0 | 3184.762138 | GARZA O | 1 | 1 | H | MIKE S |  |  |  |  | 07-027 |  |  |  |  |  |
| 121613040M |  | Viewer Sys PED Comp++ | milestone | 0d | 2009-09-15 A | 2009-09-15 A | 121613030, 121613035 | 100% | 2009-10-14 | 2009-10-14 |  |  |  |  |  |  |  | 0 | GARZA O | 1 | 1 | M | MIKE S |  | 6 |  |  | 07-027 |  |  |  |  |  |
| 121613045 |  | Re-Baseline Actuals Adjustment |  | 1d | 2013-08-30 A | 2013-08-30 A |  | 100% | 2013-09-03 | 2013-09-03 | PROCUREMENT>$50K 69 NO ESCALATION | 8,544.56 |  |  |  |  |  | 8544.56 |  |  |  |  |  |  |  |  |  |  | 0 | 8544.56 | 854456 | 100 | ADJ |

| ID | WBS | Activity | Type | Duration | Start | Finish | Predecessors | Complete | Planned start | Planned finish | Resources | Cost | Actual cost | Planned FinishUDF | LOE Divider | LOE Multiplier | Calculated Remaining Total Cost | MONTHLY EV COST | RESP - Responsibility | STRT%COMP for CM EVM | FNSH%COMP for CM EVM | CR 07-027 | EVMS Reporting Codes | CAM RESPONSIBLE | CR 09-012 | Milestone Level | Profile change | CR 08-058 | Claimed Material Divider | ReBaseline Actuals Adjustment | Remaining Material Cost Based on % Compl | Claimed Material Cost Based on % Complet | Initial Claimed Material Calc |
| --- | --- | --- | --- | --- | --- | --- | --- | --- | --- | --- | --- | --- | --- | --- | --- | --- | --- | --- | --- | --- | --- | --- | --- | --- | --- | --- | --- | --- | --- | --- | --- | --- | --- |
|  | 4 | **1.2.1.6.1.4 BEAM-BASED FEEDBACK SYSTEMS** |  |  | 2006-10-02 | 2013-08-30 |  |  |  |  |  |  |  |  |  |  |  |  |  |  |  |  |  |  |  |  |  |  |  |  |  |  |  |
| 121614007LOE |  | FY07 Management Effort for Beam Based Feedback (BEAM-BASED FB SYS) |  | 247d | 2006-10-02 A | 2007-09-28 A | 9-070M | 100% |  |  | SR STAFF [34.8 h] | 3,466.55 | 3,466.55 | 2007-09-28 | 100 | 100 | 0 | 3466.5498 | GARZA O | 1 | 1 | 07-027 | N/A | MIKE S | 09-012 |  |  |  |  |  |  |  |  |
| 121614010 |  | Define System Requirements & High Level Design (BEAM-BASED FB SYS) |  | 40d | 2007-04-02 A | 2007-05-25 A | 9-070M | 100% |  |  | SCIENTIST [45.24 h]; COMP SCIENT [46.98 h]; ELEC ENG [46.98 h] | 8,522.96 | 8,522.96 | 2006-11-28 |  |  | 0 | 8729.0058 | GARZA O | 1 | 1 |  | N/A | MIKE S |  |  |  |  |  |  |  |  |  |
| 121614011 |  | Preliminary Design & Safety Review Beam Based Feedback Systems (BEAM-BASED FB SYS) |  | 38d | 2007-05-01 A | 2007-06-22 A | 121614010 FS+58d | 100% |  |  | ELEC ENG [6.96 h] | 432.36 | 432.36 | 2007-03-01 |  |  | 0 | 459.8472 | GARZA O | 1 | 1 |  | N/A | MIKE S |  |  |  |  |  |  |  |  |  |
| 121614015M |  | Complete Preliminary Design & Safety Review BBFB (BEAM-BASED FB SYS) | milestone | 0d | 2007-06-22 A | 2007-06-22 A | 121614011 | 100% | 2007-03-01 | 2007-03-01 |  |  |  | 2007-03-01 |  |  |  | 0 | GARZA O | 1 | 1 |  | N/A | MIKE S |  | 5 |  |  |  |  |  |  |  |
| 121614020M |  | Ready to Baseline Beam Based Feedback System (BEAM-BASED FB SYS) | milestone | 0d | 2007-06-22 A | 2007-06-22 A | 121614010 FS+59d | 100% | 2007-03-01 | 2007-03-01 |  |  |  | 2007-03-01 |  |  |  | 0 | GARZA O | 1 | 1 |  | N/A | MIKE S |  | 9 |  |  |  |  |  |  |  |
| 121614908LOE |  | FY08 Mngmnt Effort for Beam Based Feedback 2 |  | 248d | 2007-10-01 A | 2008-09-30 A | 121614007LOE | 100% |  |  | SR STAFF [40 h] | 3,986.4 | 3,986.4 |  | 100 | 100 | 0 | 3986.4 | GARZA O | 1 | 1 |  | N/A | MIKE S |  |  |  |  |  |  |  |  |  |
| 121614026 |  | FY08 Comp BBFB Sys Dsgn |  | 40d | 2007-11-01 A | 2008-01-08 A | 9-080M, 121614020M | 100% |  |  |  |  |  |  |  |  |  | 0 | GARZA O | 1 | 1 |  | N/A | MIKE S |  |  |  |  |  |  |  |  |  |
| 121614027 |  | Pre-Constrctn Final Dsgn Review for BBFB |  | 4d | 2008-02-04 A | 2008-02-07 A | 121614026 | 100% |  |  |  |  |  |  |  |  |  | 0 | GARZA O | 1 | 1 |  | N/A | MIKE S |  |  | C |  |  |  |  |  |  |
| 13614909LOEX |  | FY09 FFB Sys Mangement Effort |  | 59d | 2008-10-01 A | 2008-12-24 A | 121614908LOE | 100% |  |  | SR STAFF [0.95 h] | 97.7 | 97.7 |  | 100 | 100 | 0 | 97.698 | GARZA O | 1 | 1 |  | E | MIKE S |  |  |  | 08-058 |  |  |  |  |  |
| 121614030 |  | Compile BBFB Hardware Prcrmnt Package (Beam-BASED FB SYS) |  | 85d | 2009-05-15 A | 2009-09-15 A | 121614027, 9-090M FS+120d | 100% |  |  | COMP SCIENT [80 h]; ELEC TECH [120 h]; SUPPLIES & MATERIALS; SCIENTIST [160 h]; ELEC ENG [120 h] | 30,887.33 | 27,586.4 |  |  |  | 0 | 30887.334591 | GARZA O | 1 | 1 | 07-027 | H | MIKE S |  |  |  |  |  |  |  |  |  |
| 121614035M |  | Beam Based Feedback PED Comp+ | milestone | 0d | 2009-09-15 A | 2009-09-15 A | 121614030 | 100% | 2009-10-14 | 2009-10-14 |  |  |  |  |  |  |  | 0 | GARZA O | 1 | 1 | 07-027 | M | MIKE S |  | 6 |  |  |  |  |  |  |  |
| 121614040 |  | Re-Baseline Actuals Adjustment |  | 1d | 2013-08-30 A | 2013-08-30 A |  | 100% | 2013-09-03 | 2013-09-03 | PROCUREMENT>$50K 69 NO ESCALATION | -40,115.07 |  |  |  |  |  |  |  |  |  |  |  |  |  |  |  |  | 100 | ADJ |  |  |  |
|  | 2 | **1.2.1.6.2 CONTROL SYSTEM HARDWARE** |  |  | 2006-10-02 | 2013-08-30 |  |  |  |  |  |  |  |  |  |  |  |  |  |  |  |  |  |  |  |  |  |  |  |  |  |  |  |
| 12162007LOE |  | FY07 Management Effort for Control System HW (CONT SYS HW) |  | 247d | 2006-10-02 A | 2007-09-28 A | 9-070M | 100% |  |  | SR STAFF [36 h] | 3,586.09 | 3,586.09 | 2007-09-28 | 100 | 100 | 0 | 3586.086 | GARZA O | 1 | 1 |  | N/A | MIKE S | 09-012 |  |  |  |  |  |  |  |  |
| 12162010 |  | Define & Package System Layout (CONT SYS HW) |  | 95.5d | 2006-10-02 A | 2007-02-26 A | 9-070M FS+44d | 100% |  |  | ELEC ENG [34.8 h]; ELEC TECH [34.8 h] | 3,740.66 | 3,740.66 | 2007-01-12 |  |  | 0 | 3740.652 | GARZA O | 1 | 1 |  | N/A | MIKE S |  |  |  |  |  |  |  |  |  |
| 12162015 |  | Design Top-Level System Layout (CONT SYS HW) |  | 16.5d | 2007-02-01 A | 2007-02-26 A | 12162010 | 100% |  |  | ELEC ENG [23.32 h]; ELEC TECH [23.32 h]; ELEC DES [57.77 h] | 5,104.64 | 5,104.64 | 2007-02-14 |  |  | 0 | 5104.64148 | GARZA O | 1 | 1 |  | N/A | MIKE S |  |  |  |  |  |  |  |  |  |
| 12162016 |  | Preliminary Design & Safety Review Control System Hardware (CONT SYS HW) |  | 49d | 2007-02-20 A | 2007-04-27 A | 12162015 FS+11d | 100% |  |  | COMP SCIENT [6.96 h] | 403.66 | 403.66 | 2007-03-05 |  |  | 0 | 403.1232 | GARZA O | 1 | 1 |  | N/A | MIKE S |  |  |  |  |  |  |  |  |  |
| 12162020M |  | Complete Preliminary Design & Safety Review Control System HW (CONT SYS HW) | milestone | 0d | 2007-05-31 A | 2007-05-31 A | 12162016 | 100% | 2007-03-05 | 2007-03-05 |  |  |  | 2007-03-05 |  |  |  | 0 | GARZA O | 1 | 1 |  | N/A | MIKE S |  | 5 |  |  |  |  |  |  |  |
| 12162025M |  | Ready to Baseline Control System Hardware (CONT SYS HW) | milestone | 0d | 2007-05-31 A | 2007-05-31 A | 12162020M, 12163020M, 12162015 FS+12d | 100% | 2007-03-05 | 2007-03-05 |  |  |  | 2007-03-05 |  |  |  | 0 | GARZA O | 1 | 1 |  | N/A | MIKE S |  | 9 |  |  |  |  |  |  |  |
| 12162908LOE |  | FY08 Mngmnt Effort for Control Sys HW 2 |  | 248d | 2007-10-01 A | 2008-09-30 A | 12162007LOE | 100% |  |  | SR STAFF [80 h] | 7,972.8 | 7,972.8 |  | 100 | 100 | 0 | 7972.8 | GARZA O | 1 | 1 |  | N/A | MIKE S |  |  |  |  |  |  |  |  |  |
| 12162026 |  | FY08 Comp CSH Sys Dsgn |  | 160d | 2007-11-01 A | 2008-06-30 A | 12162025M, 9-080M | 100% | 2007-11-01 | 2008-06-27 |  |  |  |  |  |  |  | 0 | GARZA O | 1 | 1 |  | N/A | MIKE S |  |  |  |  |  |  |  |  |  |
| 12162027 |  | Pre-Constrctn Final Dsgn Review for CSH |  | 21d | 2008-05-01 A | 2008-05-30 A | 12162026 | 100% |  |  |  |  |  |  |  |  |  | 0 | GARZA O | 1 | 1 |  | Z | MIKE S |  |  | C |  |  |  |  |  |  |
| 1362909LOEX |  | FY09 CSH Sys Mngmnt Effort |  | 59d | 2008-10-01 A | 2008-12-24 A | 12162908LOE | 100% |  |  | SR STAFF [0.95 h] | 97.7 | 97.7 |  | 100 | 100 | 0 | 97.698 | GARZA O | 1 | 1 |  | E | MIKE S |  |  |  | 08-058 |  |  |  |  |  |
| 12162035 |  | Compile CSH Prcrmnt Packages |  | 85d | 2009-05-15 A | 2009-09-15 A | 12162027, 9-090M | 100% |  |  | SUPPLIES & MATERIALS; ELEC ENG [160 h] | 11,373.56 | 10,276.8 |  |  |  | 0 | 11373.562138 | GARZA O | 1 | 1 | 07-027 | H | MIKE S |  |  |  |  |  |  |  |  |  |
| 12162040M |  | PED for Control Sys Hardware Comp+ | milestone | 0d | 2009-09-15 A | 2009-09-15 A | 12162035 | 100% | 2009-10-14 | 2009-10-14 |  |  |  |  |  |  |  | 0 | GARZA O | 1 | 1 | 07-027 | M | MIKE S |  | 6 |  |  |  |  |  |  |  |
| 12162045 |  | Re-Baseline Actuals Adjustment |  | 1d | 2013-08-30 A | 2013-08-30 A |  | 100% | 2013-09-03 | 2013-09-03 | PROCUREMENT>$50K 69 NO ESCALATION | 5,406.2 |  |  |  |  |  | 5406.2 |  |  |  |  |  |  |  |  |  |  | 100 | ADJ | 0 | 5406.2 | 540620 |

| ID | WBS | Activity | Type | Duration | Start | Finish | Predecessors | Complete | Planned start | Planned finish | Resources | Cost | Actual cost | Planned FinishUDF | LOE Divider | LOE Multiplier | Calculated Remaining Total Cost | MONTHLY EV COST | RESP - Responsibility | STRT%COMP for CM EVM | FNSH%COMP for CM EVM | EVMS Reporting Codes | CAM RESPONSIBLE | CR 09-012 | Milestone Level | CR 08-058 | CR 07-027 | Profile change | Claimed Material Divider | ReBaseline Actuals Adjustment | CR 07-026 | CR 08-031 | Remaining Material Cost Based on % Compl | Claimed Material Cost Based on % Complet | Initial Claimed Material Calc | WBS ASSIGNMENT | EXPNS ACT BRIDGING FY SPLIT | CR 09-001 |
| --- | --- | --- | --- | --- | --- | --- | --- | --- | --- | --- | --- | --- | --- | --- | --- | --- | --- | --- | --- | --- | --- | --- | --- | --- | --- | --- | --- | --- | --- | --- | --- | --- | --- | --- | --- | --- | --- | --- |
|  | 3 | **1.2.1.6.3 CONTROL SYSTEM SOFTWARE** |  |  | 2006-10-02 | 2013-08-30 |  |  |  |  |  |  |  |  |  |  |  |  |  |  |  |  |  |  |  |  |  |  |  |  |  |  |  |  |  |  |  |  |
| 12163007LOE |  | FY07 Management Effort for Control System Software (CONT SYS SW) |  | 247d | 2006-10-02 A | 2007-09-28 A | 9-070M | 100% |  |  | SR STAFF [34.8 h] | 3,466.55 | 3,466.55 | 2007-09-28 | 100 | 100 | 0 | 3466.5498 | BICKLEY M | 1 | 1 | N/A | MIKE S | 09-012 |  |  |  |  |  |  |  |  |  |  |  |  |  |  |
| 12163010 |  | Identify and document hall dependecies (CONT SYS SW) |  | 58d | 2006-10-02 A | 2006-12-22 A | 9-070M | 100% |  |  | COMP SCIENT [52.2 h] | 3,023.42 | 3,023.42 | 2006-11-28 |  |  | 0 | 3023.424 | BICKLEY M | 1 | 1 | N/A | MIKE S |  |  |  |  |  |  |  |  |  |  |  |  |  |  |  |
| 12163015 |  | Identify and document HLA modifications (CONT SYS SW) |  | 134d | 2007-01-18 A | 2007-07-27 A | 9-070M | 100% |  |  | COMP SCIENT [52.2 h] | 3,014.52 | 3,014.52 | 2006-11-28 |  |  | 0 | 3023.424 | BICKLEY M | 1 | 1 | N/A | MIKE S |  |  |  |  |  |  |  |  |  |  |  |  |  |  |  |
| 12163020 |  | Preliminary Design & Safety Review Control System Software (CONT SYS SW) |  | 20d | 2007-04-09 A | 2007-05-04 A | 12163015 FS+39d, 12163010 FS+39d | 100% |  |  | COMP SCIENT [6.96 h] | 404.45 | 404.45 | 2007-02-01 |  |  | 0 | 403.1232 | BICKLEY M | 1 | 1 | N/A | MIKE S |  |  |  |  |  |  |  |  |  |  |  |  |  |  |  |
| 12163020M |  | Complete Preliminary Design & Safety Review Control System SW (CONT SYS SW) | milestone | 0d | 2007-05-04 A | 2007-05-04 A | 12163020 | 100% | 2007-02-01 | 2007-02-01 |  |  |  | 2007-02-01 |  |  |  | 0 | BICKLEY M | 1 | 1 | N/A | MIKE S |  | 5 |  |  |  |  |  |  |  |  |  |  |  |  |  |
| 12163025M |  | Ready to Baseline Control System Software (CONT SYS SW) | milestone | 0d | 2007-06-29 A | 2007-06-29 A | 12163015 FS+40d | 100% | 2007-02-01 | 2007-02-01 |  |  |  | 2007-02-01 |  |  |  | 0 | BICKLEY M | 1 | 1 | N/A | MIKE S |  | 9 |  |  |  |  |  |  |  |  |  |  |  |  |  |
| 12163908LOE |  | FY08 Mngmnt Effort for Control Sys Software 2 |  | 248d | 2007-10-01 A | 2008-09-30 A | 12163007LOE, 9-080M | 100% |  |  | SR STAFF [80 h] | 7,972.8 | 7,972.8 |  | 100 | 100 | 0 | 7972.8 | BICKLEY M | 1 | 1 | N/A | MIKE S |  |  |  |  |  |  |  |  |  |  |  |  |  |  |  |
| 12163035 |  | FY08 Finalize Application Rquirmnts |  | 258d | 2008-01-11 A | 2009-01-26 A | 12163025M, 9-080M | 100% |  |  | COMP SCIENT [280 h] | 16,353.37 | 16,353.37 |  |  |  | 0 | 16203.6 | BICKLEY M | 1 | 1 | N/A | MIKE S |  |  |  |  |  |  |  |  |  |  |  |  |  |  |  |
| 1363909LOEX |  | FY09 CSS Sys Mngmnt Effort |  | 59d | 2008-10-01 A | 2008-12-24 A | 12163908LOE | 100% |  |  | SR STAFF [5.71 h] | 587.22 | 587.22 |  | 100 | 100 | 0 | 587.2164 | BICKLEY M | 1 | 1 | E | MIKE S |  |  | 08-058 |  |  |  |  |  |  |  |  |  |  |  |  |
| 12163040 |  | Comp Detailed Application Dsgn (CONT SYS SW) |  | 10d | 2009-01-05 A | 2009-01-19 A | 12163035 FS-70d | 100% | 2009-01-05 | 2009-01-16 | COMP SCIENT [280 h] | 16,718.8 | 16,718.8 |  |  |  | 0 | 16203.6 | BICKLEY M | 1 | 1 | H | MIKE S |  |  |  | 07-027 |  |  |  |  |  |  |  |  |  |  |  |
| 12163045 |  | Comp Implementn Plan (CONT SYS SW) |  | 10d | 2009-01-12 A | 2009-01-26 A | 12163040 | 100% |  |  | COMP SCIENT [320 h]; SUPPLIES & MATERIALS | 22,514.62 | 19,107.2 |  |  |  | 0 | 22514.616352 | BICKLEY M | 1 | 1 | H | MIKE S |  |  |  | 07-027 |  |  |  |  |  |  |  |  |  |  |  |
| 12163050M |  | Control Sys Software PED Comp+ | milestone | 0d | 2009-01-26 A | 2009-01-26 A | 12163045 | 100% | 2009-02-02 | 2009-02-02 |  |  |  |  |  |  |  | 0 | BICKLEY M | 1 | 1 | M | MIKE S |  | 6 |  | 07-027 |  |  |  |  |  |  |  |  |  |  |  |
| 12163170 |  | Pre-Constrctn Dsgn Review |  | 4d | 2009-09-21 A | 2009-09-24 A | 12163040 | 100% |  |  |  |  |  |  |  |  |  | 0 | BICKLEY M | 1 | 1 | Z | MIKE S |  |  |  |  | C |  |  |  |  |  |  |  |  |  |  |
| 12163175 |  | Re-Baseline Actuals Adjustment |  | 1d | 2013-08-30 A | 2013-08-30 A |  | 100% | 2013-09-03 | 2013-09-03 | PROCUREMENT>$50K 69 NO ESCALATION | -36,894.1 |  |  |  |  |  |  |  |  |  |  |  |  |  |  |  |  | 100 | ADJ |  |  |  |  |  |  |  |  |
|  | 4 | **1.2.1.6.4 SAFETY SYSTEMS** |  |  | 2006-10-02 | 2013-08-30 |  |  |  |  |  |  |  |  |  |  |  |  |  |  |  |  |  |  |  |  |  |  |  |  |  |  |  |  |  |  |  |  |
|  | 1 | **1.2.1.6.4.1 MACHINE PROTECTION** |  |  | 2006-10-02 | 2013-08-30 |  |  |  |  |  |  |  |  |  |  |  |  |  |  |  |  |  |  |  |  |  |  |  |  |  |  |  |  |  |  |  |  |
| 121641007LOE |  | FY07 Management effort for Machine Protection Systems (MACHINE PROTECT) |  | 247d | 2006-10-02 A | 2007-09-28 A | 9-070M | 100% |  |  | SR STAFF [34.8 h] | 3,466.55 | 3,466.55 | 2007-09-28 | 100 | 100 | 0 | 3466.5498 | MAHONEY K | 1 | 1 | N/A | MIKE S | 09-012 |  |  |  |  |  |  |  |  |  |  |  |  |  |  |
| 121641010 |  | Define MPS System Requirements (MACHINE PROTECT) |  | 162d | 2006-11-01 A | 2007-06-29 A | 9-070M FS+22d | 100% |  |  | ELEC ENG [27.84 h] | 1,795.94 | 1,795.94 | 2006-12-22 |  |  | 0 | 1795.944652 | MAHONEY K | 1 | 1 | N/A | MIKE S |  |  |  |  |  |  |  | 07-026 |  |  |  |  |  |  |  |
| 121641025 |  | Design and Test Eng Dev Ion Chamber (MACHINE PROTECT) |  | 131d | 2006-12-18 A | 2007-06-29 A | 9-070M FS+53d | 100% |  |  | ELEC DES [5.2 h]; ELEC TECH [26.08 h]; SCIENTIST [5.2 h]; SUPPLIES & MATERIALS; ELEC ENG [26.08 h] | 3,704.2 | 3,291.4 | 2007-04-13 |  |  | 0 | 3704.194693 | MAHONEY K | 1 | 1 | N/A | MIKE S |  |  |  |  |  |  |  | 07-026 |  |  |  |  |  |  |  |
| 121641015 |  | Design System Detail Architecture (MACHINE PROTECT) |  | 98d | 2007-02-12 A | 2007-06-29 A | 9-070M FS+86d | 100% |  |  | ELEC ENG [22.62 h] | 1,436.15 | 1,436.15 | 2007-04-04 |  |  | 0 | 1436.153033 | MAHONEY K | 1 | 1 | N/A | MIKE S |  |  |  |  |  |  |  | 07-026 |  |  |  |  |  |  |  |
| 121641020 |  | Design FSD Master (MACHINE PROTECT) |  | 74d | 2007-03-19 A | 2007-06-29 A | 9-070M FS+110d | 100% |  |  | ELEC DES [15.34 h]; ELEC ENG [15.08 h]; SUPPLIES & MATERIALS; ELEC TECH [37.44 h] | 3,450.71 | 3,115.31 | 2007-05-31 |  |  | 0 | 3450.711286 | MAHONEY K | 1 | 1 | N/A | MIKE S |  |  |  |  |  |  |  | 07-026 |  |  |  |  |  |  |  |
| 121641030 |  | Complete Internal Preliminary Design & Safety Review (MACHINE PROTECT) |  | 29d | 2007-05-14 A | 2007-06-22 A | 121641010A FS-34d, 121641015A FS-75d, 121641020A FS-55d | 100% |  |  | ELEC ENG [17.2 h] | 1,068.46 | 1,068.46 | 2007-03-21 |  |  | 0 | 1070.528 | MAHONEY K | 1 | 1 | N/A | MIKE S |  |  |  |  |  |  |  |  |  |  |  |  |  |  |  |
| 121641035 |  | Complete External Preliminary Design & Safety Review (MACHINE PROTECT) |  | 16d | 2007-06-04 A | 2007-06-25 A | 121641030 FS+9d | 100% |  |  | ELEC ENG [17.2 h]; TRAVEL | 2,667.91 | 1,068.46 | 2007-05-07 |  |  | 0 | 2669.973 | MAHONEY K | 1 | 1 | N/A | MIKE S |  |  |  |  |  |  |  |  |  |  |  |  |  |  |  |
| 121641040M |  | MPS 35% Design Complete (MACHINE PROTECT) | milestone | 0d | 2007-06-25 A | 2007-06-25 A | 121641035 FS+18d | 100% | 2007-12-17 | 2007-12-17 |  |  |  | 2007-06-01 |  |  |  | 0 | MAHONEY K | 1 | 1 | N/A | MIKE S |  | 5 |  |  |  |  |  |  |  |  |  |  |  |  |  |
| 121641010A |  | Define MPS System Requirements (MACHINE PROTECT) |  | 101.5d | 2007-07-09 A | 2007-11-30 A | 121641010 FS+63d | 100% |  |  | ELEC ENG [6.96 h] | 425.41 | 425.41 | 2006-12-22 |  |  | 0 | 433.1904 | MAHONEY K | 1 | 1 | N/A | MIKE S |  |  |  |  |  |  |  | 07-026 |  |  |  |  |  |  |  |
| 121641025A |  | Design and Test Eng Dev Ion Chamber (MACHINE PROTECT)++ |  | 453d | 2007-07-17 A | 2009-05-14 A | 121641025 FS+63d | 100% |  |  | ELEC DES [20.8 h]; SCIENTIST [20.8 h]; SUPPLIES & MATERIALS; ELEC ENG [104.32 h]; ELEC TECH [104.32 h] | 14,570.51 | 12,866.64 | 2007-04-13 |  |  | 0 | 14479.78368 | MAHONEY K | 1 | 1 | N/A | MIKE S |  |  |  |  |  |  |  | 07-026 |  |  |  |  |  |  |  |
| 121641015A |  | Design System Detail Architecture (MACHINE PROTECT) |  | 217d | 2007-10-01 A | 2008-08-15 A | 121641015 FS+63d | 100% |  |  | ELEC ENG [12.18 h] | 758.08 | 758.08 | 2007-04-04 |  |  | 0 | 758.0832 | MAHONEY K | 1 | 1 | N/A | MIKE S |  |  |  |  |  |  |  | 07-026 |  |  |  |  |  |  |  |
| 121641020A |  | Design FSD Master (MACHINE PROTECT) |  | 217d | 2007-10-01 A | 2008-08-15 A | 121641020 FS+63d | 100% |  |  | ELEC DES [8.26 h]; ELEC TECH [20.16 h]; ELEC ENG [8.12 h]; SUPPLIES & MATERIALS | 1,844.56 | 1,658.2 | 2007-05-31 |  |  | 0 | 1844.56174 | MAHONEY K | 1 | 1 | N/A | MIKE S |  |  |  |  |  |  |  | 07-026 |  |  |  |  |  |  |  |
| 121641045M |  | Start P-#2 of MPS PED - FY08 | milestone | 0d | 2007-10-15 A | 2007-10-15 A | 121641040M, 9-080M | 100% | 2007-11-01 | 2007-11-01 |  |  |  |  |  |  |  | 0 | MAHONEY K | 1 | 1 | N/A | MIKE S |  | 6 |  |  |  |  |  |  |  |  |  |  |  |  |  |
| 121641050 |  | Detail Dsgn FSD Sys (MACHINE PROTECT) |  | 168d | 2007-12-11 A | 2008-08-15 A | 121641045M, 9-080M | 100% |  |  | COMP SCIENT [20 h]; ELEC ENG [60 h] | 4,891.8 | 4,891.8 |  |  |  | 0 | 4891.8 | MAHONEY K | 1 | 1 | N/A | MIKE S |  |  |  |  |  |  |  |  |  |  |  |  |  |  |  |
| 121641055 |  | Develop FSD CAD Drawigns to 80% (MACHINE PROTECT)++ |  | 161d | 2008-01-14 A | 2008-08-29 A | 121641050 | 100% |  |  | ELEC TECH [40 h]; ELEC ENG [40 h]; ELEC DES [80 h] | 7,610.8 | 7,610.8 |  |  |  | 0 | 7610.8 | MAHONEY K | 1 | 1 | N/A | MIKE S |  |  |  |  |  |  |  | 07-026 |  |  |  |  |  |  |  |
| 121641060 |  | FSD Dsgn & Safty Review (MACHINE PROTECT) |  | 10d | 2008-05-16 A | 2008-05-30 A | 121641055 | 100% |  |  | ELEC ENG [40 h]; SUPPLIES & MATERIALS | 3,021.03 | 2,489.6 |  |  |  | 0 | 3021.0285 | MAHONEY K | 1 | 1 | H | MIKE S |  |  |  |  |  |  |  |  | 08-031 |  |  |  |  |  |  |
| 121641065 |  | FSD Mock-up (MACHINE PROTECT) |  | 128d | 2008-06-20 A | 2008-12-22 A | 121641055 | 100% |  |  | ELEC TECH [80 h]; PROCUREMENT<$50K 60; ELEC ENG [60 h] | 11,207.9 | 6,946.15 |  |  |  | 0 | 11110.547 | MAHONEY K | 1 | 1 | H | MIKE S |  |  |  |  |  | 100 |  | 07-026 | 08-031 | 0 | 4261.75 | 426175 |  |  |  |
| 121641070 |  | FY08 Detail Dsgn BLM Sys (MACHINE PROTECT) |  | 151d | 2008-07-03 A | 2009-02-16 A | 121641065 | 100% | 2008-07-03 | 2009-02-13 | ELEC ENG [93.33 h]; SCIENTIST [31.11 h]; MECH DES [31.11 h]; COMP SCIENT [62.22 h] | 12,906.68 | 12,906.68 |  |  |  | 0 | 12668.3031 | MAHONEY K | 1 | 1 | H | MIKE S |  |  |  |  |  |  |  | 07-026 | 08-031 |  |  |  | 1.2.1.6.4.1 | EXP0809 | 09-001 |
| 121641075 |  | Develop BLM CAD Drawigns to 80% (MACHINE PROTECT)++ |  | 148d | 2008-07-21 A | 2009-02-26 A | 121641070a | 100% |  |  | ELEC DES [60 h]; ELEC TECH [60 h]; ELEC ENG [80 h] | 10,197.33 | 10,197.33 |  |  |  | 0 | 10307.4 | MAHONEY K | 1 | 1 | H | MIKE S |  |  |  |  |  |  |  | 07-026 | 08-031 |  |  |  |  |  |  |
| 13641909LOEX |  | FY09 Mngmnt & Elect Dsgn Supprt Effort for MPS |  | 59d | 2008-10-01 A | 2008-12-24 A | 9-090M, 121642908LOE | 100% |  |  | SR STAFF [0.95 h]; ELEC DES [0.95 h] | 141.38 | 141.38 |  | 100 | 100 | 0 | 141.379 | MAHONEY K | 1 | 1 | E | MIKE S |  |  | 08-058 |  |  |  |  |  |  |  |  |  |  |  |  |
| 121641070a |  | FY09 Detail Dsgn BLM Sys (MACHINE PROTECT) |  | 61d | 2008-11-10 A | 2009-02-16 A | 121641070 FS-250d | 100% | 2008-11-10 | 2009-02-13 | SCIENTIST [8.89 h]; COMP SCIENT [17.78 h]; ELEC ENG [26.67 h]; MECH DES [8.89 h] | 3,735.66 | 3,735.66 |  |  |  | 0 | 3735.6669 | MAHONEY K | 1 | 1 | H | MIKE S |  |  |  |  |  |  |  | 07-026 | 08-031 |  |  |  | 1.2.1.6.4.1 | EXP0809 | 09-001 |
| 121641085 |  | BLM Mock-up (MACHINE PROTECT) |  | 46d | 2009-02-04 A | 2009-04-09 A | 121641075 | 100% |  |  | PROCUREMENT<$50K 60; ELEC ENG [20 h]; ELEC TECH [80 h] | 9,108.86 | 4,498.2 |  |  |  | 0 | 9108.863347 | MAHONEY K | 1 | 1 | H | MIKE S | 09-012 |  |  |  |  | 100 |  | 07-026 | 08-031 | 0 | 4610.66 | 461066 |  |  |  |
| 121641100 |  | Develop FSD Proc Packages (MACHINE PROTECT)++ |  | 91.5d | 2009-03-16 A | 2009-07-23 A | 121641095 FS-40d | 100% |  |  | ELEC TECH [40 h]; ELEC ENG [60 h] | 5,460.6 | 5,460.6 |  |  |  | 0 | 5460.6 | MAHONEY K | 1 | 1 | H | MIKE S |  |  |  |  |  |  |  | 07-026 | 08-031 |  |  |  |  |  |  |
| 121641105 |  | Develop BLM Proc Packages (MACHINE PROTECT)++ |  | 91.5d | 2009-03-16 A | 2009-07-23 A | 121641095 FS-40d | 100% |  |  | ELEC ENG [40 h]; ELEC TECH [40 h]; SR STAFF [40 h] | 8,289.6 | 8,289.6 |  |  |  | 0 | 8289.6 | MAHONEY K | 1 | 1 | H | MIKE S |  |  |  |  |  |  |  | 07-026 | 08-031 |  |  |  |  |  |  |
| 121641080 |  | BLM Dsgn Review (MACHINE PROTECT) |  | 96d | 2009-05-01 A | 2009-09-16 A | 121641075 | 100% |  |  | ELEC ENG [40 h]; SUPPLIES & MATERIALS | 3,117.58 | 2,569.2 |  |  |  | 0 | 3117.581069 | MAHONEY K | 1 | 1 | H | MIKE S |  |  |  |  |  |  |  | 07-026 | 08-031 |  |  |  |  |  |  |
| 121641090 |  | Machine Protection Sys Dsgn & Safty Review |  | 68d | 2009-06-25 A | 2009-09-30 A | 121641060, 121641080 FS-500d | 100% |  |  | ELEC ENG [80 h]; TRAVEL | 7,449.05 | 5,138.4 |  |  |  | 0 | 7449.054214 | MAHONEY K | 1 | 1 | H | MIKE S |  |  |  |  |  |  |  | 07-026 | 08-031 |  |  |  |  |  |  |
| 121641170 |  | Pre-Constrctn Dsgn Review++ |  | 63.5d | 2009-07-01 A | 2009-09-30 A | 121641110M FS-110d | 100% |  |  |  |  |  |  |  |  |  | 0 | MAHONEY K | 1 | 1 | Z | MIKE S |  |  |  |  | C |  |  | 07-026 | 08-031 |  |  |  |  |  |  |
| 121641095 |  | Update MPS Dsgn Based on Desgin Review |  | 8d | 2009-09-21 A | 2009-09-30 A | 121641090 | 100% |  |  | ELEC ENG [20 h]; ELEC DES [20 h] | 2,204.2 | 2,204.2 |  |  |  | 0 | 2204.2 | MAHONEY K | 1 | 1 | H | MIKE S |  |  |  |  |  |  |  | 07-026 | 08-031 |  |  |  |  |  |  |
| 121641110M |  | MPS PED Comp++ | milestone | 0d | 2009-09-30 A | 2009-09-30 A | 121641025A, 121641085, 121641105, 121641065, 121641100 | 100% | 2009-10-01 | 2009-10-01 |  |  |  |  |  |  |  | 0 | MAHONEY K | 1 | 1 | M | MIKE S |  | 6 |  |  |  |  |  |  | 08-031 |  |  |  |  |  |  |
| 121641175 |  | Re-Baseline Actuals Adjustment |  | 1d | 2013-08-30 A | 2013-08-30 A |  | 100% | 2013-09-03 | 2013-09-03 | PROCUREMENT>$50K 69 NO ESCALATION | 43,713.68 |  |  |  |  |  | 43713.68 |  |  |  |  |  |  |  |  |  |  | 100 | ADJ |  |  | 0 | 43713.68 | 4371368 |  |  |  |

| ID | WBS | Activity | Type | Duration | Start | Finish | Predecessors | Complete | Planned start | Planned finish | Resources | Cost | Actual cost | Planned FinishUDF | LOE Divider | LOE Multiplier | Calculated Remaining Total Cost | MONTHLY EV COST | RESP - Responsibility | STRT%COMP for CM EVM | FNSH%COMP for CM EVM | EVMS Reporting Codes | CAM RESPONSIBLE | CR 09-012 | CR 07-026 | Milestone Level | Remaining Material Cost Based on % Compl | Claimed Material Cost Based on % Complet | Initial Claimed Material Calc | Claimed Material Divider | CR 08-031 | CR 08-058 | Profile change | ReBaseline Actuals Adjustment | WBS ASSIGNMENT | EXPNS ACT BRIDGING FY SPLIT | CR 09-001 |
| --- | --- | --- | --- | --- | --- | --- | --- | --- | --- | --- | --- | --- | --- | --- | --- | --- | --- | --- | --- | --- | --- | --- | --- | --- | --- | --- | --- | --- | --- | --- | --- | --- | --- | --- | --- | --- | --- |
|  | 2 | **1.2.1.6.4.2 BELS** |  |  | 2006-10-02 | 2013-08-30 |  |  |  |  |  |  |  |  |  |  |  |  |  |  |  |  |  |  |  |  |  |  |  |  |  |  |  |  |  |  |  |
| 121642007LOE |  | FY07 Management Effort for Beam Envelope Limit System (BELS) |  | 247d | 2006-10-02 A | 2007-09-28 A | 9-070M | 100% |  |  | SR STAFF [34.8 h] | 3,466.55 | 3,466.55 | 2007-09-28 | 100 | 100 | 0 | 3466.5498 | MAHONEY K | 1 | 1 | N/A | MIKE S | 09-012 |  |  |  |  |  |  |  |  |  |  |  |  |  |
| 121642010 |  | Define BELS System Requirements (BELS) |  | 89d | 2007-02-26 A | 2007-06-29 A | 9-070M FS+95d | 100% |  |  | ELEC ENG [27.84 h] | 1,760.31 | 1,760.31 | 2007-03-21 |  |  | 0 | 1760.310688 | MAHONEY K | 1 | 1 | N/A | MIKE S |  | 07-026 |  |  |  |  |  |  |  |  |  |  |  |  |
| 121642015 |  | Design and Test Eng Dev BELS - Hall D Interface (BELS) |  | 34d | 2007-05-14 A | 2007-06-29 A | 9-070M FS+150d | 100% |  |  | ELEC TECH [34.8 h]; ELEC ENG [17.4 h]; SUPPLIES & MATERIALS | 3,476.79 | 2,446.79 | 2007-04-27 |  |  | 0 | 3476.788 | MAHONEY K | 1 | 1 | N/A | MIKE S |  | 07-026 |  |  |  |  |  |  |  |  |  |  |  |  |
| 121642020M |  | Complete Preliminary Design & Safety Review (BELS) | milestone | 0d | 2007-06-25 A | 2007-06-25 A | 121642015 FS+12d | 100% | 2007-07-18 | 2007-07-18 |  |  |  | 2007-05-15 |  |  |  | 0 | MAHONEY K | 1 | 1 | N/A | MIKE S |  |  | 5 |  |  |  |  |  |  |  |  |  |  |  |
| 121642025M |  | 35% Design Complete (BELS) | milestone | 0d | 2007-06-25 A | 2007-06-25 A | 121642020M | 100% | 2007-07-18 | 2007-07-18 |  |  |  | 2007-05-15 |  |  |  | 0 | MAHONEY K | 1 | 1 | N/A | MIKE S |  |  | 5 |  |  |  |  |  |  |  |  |  |  |  |
| 121642010A |  | Define BELS System Requirements (BELS) |  | 274d | 2007-07-16 A | 2008-08-20 A | 121642010 FS+63d | 100% |  |  | ELEC ENG [6.96 h] | 430.55 | 430.55 | 2007-03-21 |  |  | 0 | 433.1904 | MAHONEY K | 1 | 1 | N/A | MIKE S |  | 07-026 |  |  |  |  |  |  |  |  |  |  |  |  |
| 121642015A |  | Design and Test Eng Dev BELS - Hall D Interface (BELS) |  | 344d | 2007-10-01 A | 2009-02-25 A | 121642010 FS+17d, 121642015 FS+63d | 100% |  |  | ELEC TECH [34.8 h]; SUPPLIES & MATERIALS; ELEC ENG [17.4 h] | 3,522.31 | 2,459.45 | 2007-04-27 |  |  | 0 | 3500.597 | MAHONEY K | 1 | 1 | N/A | MIKE S |  | 07-026 |  |  |  |  |  |  |  |  |  |  |  |  |
| 121642030M |  | Start P-#2 of BELS PED - FY08 | milestone | 0d | 2007-10-01 A | 2007-10-01 A | 9-080M, 121642025M | 100% | 2007-11-01 | 2007-11-01 |  |  |  |  |  |  |  | 0 | MAHONEY K | 1 | 1 | N/A | MIKE S |  |  | 6 |  |  |  |  |  |  |  |  |  |  |  |
| 121642035 |  | Develop Detail Dsgn (BELS) |  | 314d | 2007-10-01 A | 2009-01-12 A | 121642030M | 100% |  |  | ELEC ENG [80 h] | 5,012.66 | 5,012.66 |  |  |  | 0 | 4979.2 | MAHONEY K | 1 | 1 | N/A | MIKE S |  | 07-026 |  |  |  |  |  |  |  |  |  |  |  |  |
| 121642908LOE |  | FY08 Mngmnt Effort for BELS |  | 248d | 2007-10-01 A | 2008-09-30 A | 121641007LOE, 121642007LOE, 121643007LOE, 121614007LOE | 100% |  |  | SR STAFF [40 h] | 3,986.4 | 3,986.4 |  | 100 | 100 | 0 | 3986.4 | MAHONEY K | 1 | 1 | N/A | MIKE S |  |  |  |  |  |  |  |  |  |  |  |  |  |  |
| 121642040 |  | Develop mock-up (BELS) |  | 214d | 2008-03-04 A | 2009-01-12 A | 121642035 FS-40d | 100% |  |  | ELEC ENG [20 h]; ELEC TECH [40 h]; SUPPLIES & MATERIALS | 3,361 | 2,829.57 |  |  |  | 0 | 3333.4285 | MAHONEY K | 1 | 1 | N/A | MIKE S |  | 07-026 |  |  |  |  |  |  |  |  |  |  |  |  |
| 121642045 |  | Develop CAD Drawings to 80% BELS |  | 282d | 2008-03-04 A | 2009-04-20 A | 121642035 FS-40d | 100% |  |  | ELEC DES [40 h]; ELEC ENG [20 h] | 3,072.89 | 3,072.89 |  |  |  | 0 | 3026.8 | MAHONEY K | 1 | 1 | N/A | MIKE S |  | 07-026 |  |  |  |  |  |  |  |  |  |  |  |  |
| 121642050 |  | Dsgn Review BELS |  | 30d | 2008-05-19 A | 2008-06-30 A | 121642045 | 100% |  |  | PROCUREMENT<$50K 60; SUPPLIES & MATERIALS | 2,770.65 |  |  |  |  | 0 | 2770.6515 | MAHONEY K | 1 | 1 | H | MIKE S |  | 07-026 |  | 0 | 2239.22 | 223922 | 100 | 08-031 |  |  |  |  |  |  |
| 121642055 |  | Update Dsgn Based on Dsgn Review BELS |  | 6d | 2008-07-21 A | 2008-07-28 A | 121642050 | 100% |  |  |  |  |  |  |  |  |  | 0 | MAHONEY K | 1 | 1 | Z | MIKE S |  | 07-026 |  |  |  |  |  | 08-031 |  |  |  |  |  |  |
| 13642909LOEX |  | FY09 Mngmnt & Elect Dsgn Supprt Effort for BELS |  | 59d | 2008-10-01 A | 2008-12-24 A | 121642908LOE | 100% |  |  | SR STAFF [0.95 h]; ELEC DES [0.95 h] | 141.38 | 141.38 |  | 100 | 100 | 0 | 141.379 | MAHONEY K | 1 | 1 | E | MIKE S |  |  |  |  |  |  |  |  | 08-058 |  |  |  |  |  |
| 121642060 |  | Develop Proc Packages BELS++ |  | 89d | 2009-01-13 A | 2009-05-19 A | 121642055 | 100% |  |  |  |  |  |  |  |  |  | 0 | MAHONEY K | 1 | 1 | Z | MIKE S |  | 07-026 |  |  |  |  |  | 08-031 |  |  |  |  |  |  |
| 121642070M |  | BELS PED Comp++ | milestone | 0d | 2009-05-19 A | 2009-05-19 A | 121642040, 121642060 | 100% | 2009-06-01 | 2009-06-01 |  |  |  |  |  |  |  | 0 | MAHONEY K | 1 | 1 | M | MIKE S |  |  | 6 |  |  |  |  | 08-031 |  |  |  |  |  |  |
| 121642170 |  | Pre-Constrctn Dsgn Review++ |  | 64d | 2009-07-01 A | 2009-09-30 A | 121642070M | 100% |  |  |  |  |  |  |  |  |  | 0 | MAHONEY K | 1 | 1 | Z | MIKE S |  |  |  |  |  |  |  | 08-031 |  | C |  |  |  |  |
| 121642175 |  | Re-Baseline Actuals Adjustment |  | 1d | 2013-08-30 A | 2013-08-30 A |  | 100% | 2013-09-03 | 2013-09-03 | PROCUREMENT>$50K 69 NO ESCALATION | -2,451.17 |  |  |  |  |  |  |  |  |  |  |  |  |  |  |  |  |  | 100 |  |  |  | ADJ |  |  |  |
|  | 3 | **1.2.1.6.4.3 PSS** |  |  | 2006-10-02 | 2013-08-30 |  |  |  |  |  |  |  |  |  |  |  |  |  |  |  |  |  |  |  |  |  |  |  |  |  |  |  |  |  |  |  |
| 121643007LOE |  | FY07 Management effort for Personnel Safety Systems (PSS) |  | 247d | 2006-10-02 A | 2007-09-28 A | 9-070M | 100% |  |  | SCIENTIST [34.8 h] | 2,193.82 | 2,193.82 | 2007-09-28 | 100 | 100 | 0 | 2193.821404 | MAHONEY K | 1 | 1 | N/A | MIKE S |  |  |  |  |  |  |  |  |  |  |  |  |  |  |
| 121643010 |  | Define Programmable Electronics Specification (PSS) |  | 184d | 2006-10-02 A | 2007-06-29 A | 9-070M | 100% |  |  | ELEC ENG [93.96 h] | 6,078.84 | 6,078.84 | 2006-10-13 |  |  | 0 | 6078.84433 | MAHONEY K | 1 | 1 | N/A | MIKE S |  | 07-026 |  |  |  |  |  |  |  |  |  |  |  |  |
| 121643035 |  | Test Safety PLC 1 & PLC 2 (PSS) |  | 140d | 2006-10-02 A | 2007-04-27 A | 121643010 FS-220d | 100% |  |  | ELEC TECH [226.2 h]; ELEC ENG [121.8 h] | 17,277.68 | 17,277.68 | 2007-04-27 |  |  | 0 | 17277.678 | MAHONEY K | 1 | 1 | N/A | MIKE S |  |  |  |  |  |  |  |  |  |  |  |  |  |  |
| 121643040 |  | Attend Training for Safety PLC Software (PSS) |  | 111d | 2006-10-02 A | 2007-03-19 A | 9-070M | 100% |  |  | TRAVEL; ELEC ENG [69.6 h] | 8,726.47 | 4,598.47 | 2007-02-12 |  |  | 0 | 8726.472 | MAHONEY K | 1 | 1 | N/A | MIKE S |  |  |  |  |  |  |  |  |  |  |  |  |  |  |
| 121643015 |  | Write PSS Systems Safety Specificaiton (PSS) |  | 150d | 2006-11-01 A | 2007-06-13 A | 9-070M FS+22d | 100% |  |  | ELEC ENG [104.4 h] | 6,754.75 | 6,754.75 | 2006-11-14 |  |  | 0 | 6897.708 | MAHONEY K | 1 | 1 | N/A | MIKE S |  |  |  |  |  |  |  |  |  |  |  |  |  |  |
| 121643045 |  | Design Beam Transport Monitor (PSS) |  | 162d | 2006-11-01 A | 2007-06-29 A | 121643015 FS-10d | 100% |  |  | SCIENTIST [29 h]; ELEC DES [28.8 h]; ELEC ENG [29 h] | 5,020.26 | 5,020.26 | 2007-03-30 |  |  | 0 | 5020.262765 | MAHONEY K | 1 | 1 | N/A | MIKE S |  | 07-026 |  |  |  |  |  |  |  |  |  |  |  |  |
| 121643050 |  | Construct and Test Eng Dev Beam Transport Monitor (PSS) |  | 136d | 2006-12-11 A | 2007-06-29 A | 9-070M FS+48d | 100% |  |  | ELEC TECH [12.2 h]; SUPPLIES & MATERIALS; ELEC ENG [12.2 h] | 1,482.65 | 1,276.25 | 2007-07-31 |  |  | 0 | 1482.642 | MAHONEY K | 1 | 1 | N/A | MIKE S |  | 07-026 |  |  |  |  |  |  |  |  |  |  |  |  |
| 121643070 |  | Prepare Baseline Cost Estimate (PSS) |  | 32d | 2007-03-09 A | 2007-04-23 A | 121643015, 121643035 FS-52d, 121643040, 121643010 FS-80d | 100% |  |  | ELEC ENG [69.6 h]; MECH ENG [17.4 h] | 5,538.07 | 5,538.07 | 2007-03-21 |  |  | 0 | 5575.87872 | MAHONEY K | 1 | 1 | N/A | MIKE S |  |  |  |  |  |  |  |  |  |  |  |  |  |  |
| 121643055 |  | Develop Cable Plant Design (PSS) |  | 64d | 2007-04-02 A | 2007-06-29 A | 121643015 FS+88d | 100% |  |  | ELEC DES [8.68 h]; ELEC ENG [12.2 h] | 1,148.29 | 1,148.29 | 2007-05-31 |  |  | 0 | 1148.2904 | MAHONEY K | 1 | 1 | N/A | MIKE S |  | 07-026 |  |  |  |  |  |  |  |  |  |  |  |  |
| 121643060 |  | Develop PSS Insertion Device Design (PSS) |  | 64d | 2007-04-02 A | 2007-06-29 A | 121643015 FS+88d | 100% |  |  | ELEC DES [7.8 h]; SCIENTIST [17.4 h]; MECH ENG [11.3 h]; MECH DES [7.8 h]; ELEC ENG [7.8 h] | 2,983.12 | 2,983.12 | 2007-05-03 |  |  | 0 | 2983.122 | MAHONEY K | 1 | 1 | N/A | MIKE S |  | 07-026 |  |  |  |  |  |  |  |  |  |  |  |  |
| 121643065 |  | Define PSS BCM Requirements (PSS) |  | 64d | 2007-04-02 A | 2007-06-29 A | 9-070M FS+120d | 100% |  |  | ELEC ENG [20.88 h] | 1,297.07 | 1,297.07 | 2007-02-27 |  |  | 0 | 1297.0656 | MAHONEY K | 1 | 1 | N/A | MIKE S |  | 07-026 |  |  |  |  |  |  |  |  |  |  |  |  |
| 121643080 |  | Develop Software Specification (PSS) |  | 59d | 2007-04-09 A | 2007-06-29 A | 9-070M FS+125d | 100% |  |  | ELEC ENG [17.4 h] | 1,080.89 | 1,080.89 | 2007-03-21 |  |  | 0 | 1080.888 | MAHONEY K | 1 | 1 | N/A | MIKE S |  | 07-026 |  |  |  |  |  |  |  |  |  |  |  |  |
| 121643075 |  | Prepare Review Material (PSS) |  | 25d | 2007-04-18 A | 2007-05-22 A | 121643080 FS-59d, 121643070 FS-8d | 100% |  |  | OFFICE [43.6 h]; ELEC ENG [60.9 h] | 4,905.37 | 4,905.37 | 2007-04-23 |  |  | 0 | 4905.372 | MAHONEY K | 1 | 1 | N/A | MIKE S |  |  |  |  |  |  |  |  |  |  |  |  |  |  |
| 121643020 |  | Review PSS Systems Safety Specificaiton (PSS) |  | 22d | 2007-05-14 A | 2007-06-13 A | 121643015 FS+10d | 100% |  |  | ELEC ENG [69.6 h] | 4,323.55 | 4,323.55 | 2006-12-07 |  |  | 0 | 4598.472 | MAHONEY K | 1 | 1 | N/A | MIKE S |  |  |  |  |  |  |  |  |  |  |  |  |  |  |
| 121643085 |  | Complete Design & Safety Review - External Reviewers (PSS) |  | 6d | 2007-05-14 A | 2007-05-21 A | 121643075 FS-26d, 121643065 FS-34d, 121643025 | 100% |  |  | OFFICE [43.6 h]; ELEC ENG [60.9 h]; TRAVEL | 9,033.37 | 4,905.37 | 2007-03-23 |  |  | 0 | 9033.372 | MAHONEY K | 1 | 1 | N/A | MIKE S |  |  |  |  |  |  |  |  |  |  |  |  |  |  |
| 121643025 |  | Conduct Internal PSS Design & Safety Review (PSS) |  | 1d | 2007-05-24 A | 2007-05-24 A | 121643020 FS+5d, 121643015 | 100% |  |  | ELEC ENG [34.8 h] | 2,161.78 | 2,161.78 | 2006-12-21 |  |  | 0 | 2299.236 | MAHONEY K | 1 | 1 | N/A | MIKE S |  |  |  |  |  |  |  |  |  |  |  |  |  |  |
| 121643090M |  | PSS Design 35% Complete (PSS) | milestone | 0d | 2007-06-13 A | 2007-06-13 A | 121643060, 121643060A, 121643085 FS+39d | 100% | 2008-01-25 | 2008-01-25 |  |  |  | 2007-05-17 |  |  |  | 0 | MAHONEY K | 1 | 1 | N/A | MIKE S |  |  | 5 |  |  |  |  |  |  |  |  |  |  |  |
| 121643045A |  | Design Beam Transport Monitor (PSS) |  | 366d | 2007-07-16 A | 2009-01-08 A | 121643045 FS+63d | 100% |  |  | ELEC ENG [29 h]; ELEC DES [28.8 h]; SCIENTIST [29 h] | 4,898.91 | 4,898.91 | 2007-03-30 |  |  | 0 | 4893.83 | MAHONEY K | 1 | 1 | N/A | MIKE S |  | 07-026 |  |  |  |  |  |  |  |  |  |  |  |  |
| 121643010A |  | Define Programmable Electronics Specification (PSS) |  | 280.5d | 2007-10-01 A | 2008-11-14 A | 121643010 FS+63d, 9-070M | 100% |  |  | ELEC ENG [10.45 h] | 652.94 | 652.94 | 2006-10-13 |  |  | 0 | 650.53248 | MAHONEY K | 1 | 1 | N/A | MIKE S |  | 07-026 |  |  |  |  |  |  |  |  |  |  |  |  |
| 121643055A |  | Develop Cable Plant Design (PSS) |  | 342d | 2007-10-01 A | 2009-02-23 A | 121643055 FS+63d | 100% |  |  | ELEC DES [78.12 h]; ELEC ENG [109.8 h] | 10,404.96 | 10,404.96 | 2007-05-31 |  |  | 0 | 10314.198 | MAHONEY K | 1 | 1 | N/A | MIKE S |  | 07-026 |  |  |  |  |  |  |  |  |  |  |  |  |
| 121643060A |  | Develop PSS Insertion Device Design (PSS) |  | 257d | 2007-10-01 A | 2008-10-13 A | 121643060 FS+63d | 100% |  |  | SCIENTIST [52.2 h]; MECH ENG [33.9 h]; MECH DES [23.4 h]; ELEC ENG [23.4 h]; ELEC DES [23.4 h] | 8,849.68 | 8,849.68 | 2007-05-03 |  |  | 0 | 8839.788 | MAHONEY K | 1 | 1 | N/A | MIKE S |  | 07-026 |  |  |  |  |  |  |  |  |  |  |  |  |
| 121643065A |  | Define PSS BCM Requirements (PSS) |  | 289d | 2007-10-01 A | 2008-11-26 A | 121643065 FS+63d, 9-070M FS+32d | 100% |  |  | ELEC ENG [83.52 h] | 5,221.86 | 5,221.86 | 2007-02-27 |  |  | 0 | 5198.2848 | MAHONEY K | 1 | 1 | N/A | MIKE S |  | 07-026 |  |  |  |  |  |  |  |  |  |  |  |  |
| 121643080A |  | Develop Software Specification (PSS) |  | 305d | 2007-10-01 A | 2008-12-22 A | 121643080 FS+63d | 100% |  |  | ELEC ENG [52.2 h] | 3,268.34 | 3,268.34 | 2007-03-21 |  |  | 0 | 3248.928 | MAHONEY K | 1 | 1 | N/A | MIKE S |  | 07-026 |  |  |  |  |  |  |  |  |  |  |  |  |
| 121643050A |  | Construct and Test Eng Dev Beam Transport Monitor (PSS) |  | 260d | 2007-12-17 A | 2009-01-09 A | 121643090M, 121643050 FS+53d | 100% |  |  | ELEC ENG [109.8 h]; ELEC TECH [109.8 h]; SUPPLIES & MATERIALS | 13,113.99 | 11,197.13 | 2007-07-31 |  |  | 0 | 13025.32344 | MAHONEY K | 1 | 1 | N/A | MIKE S |  | 07-026 |  |  |  |  |  |  |  |  |  |  |  |  |
| 121643100 |  | FY08 Develop PSS Detail Dsgn |  | 312.5d | 2008-01-14 A | 2009-04-15 A | 121643095M | 100% |  |  | MECH ENG [76.84 h]; ELEC ENG [845.22 h]; ELEC DES [461.03 h]; ELEC TECH [230.51 h]; SCIENTIST [76.84 h] | 92,884.58 | 92,884.58 |  |  |  | 0 | 91655.746 | MAHONEY K | 1 | 1 | N/A | MIKE S |  | 07-026 |  |  |  |  |  | 08-031 |  |  |  | 1.2.1.6.4.3 | EXP0809 | 09-001 |
| 121643095M |  | Start P-#2 of PSS PED - FY08 | milestone | 0d | 2008-05-30 A | 2008-05-30 A | 121643050, 121643050A FS-75d, 121643055, 9-080M, 121643055A | 100% | 2008-11-05 | 2008-11-05 |  |  |  |  |  |  |  | 0 | MAHONEY K | 1 | 1 | M | MIKE S |  |  | 6 |  |  |  |  | 08-031 |  |  |  |  |  |  |
| 121643105 |  | Develop PSS Mock-up & Test-bed |  | 220d | 2008-07-10 A | 2009-05-29 A | 121643095M | 100% |  |  | SUPPLIES & MATERIALS; PROCUREMENT<$50K 60; MECH TECH [40 h]; ELEC ENG [160 h]; ELEC TECH [200 h] | 60,634 | 19,766.3 |  |  |  | 0 | 60796.499872 | MAHONEY K | 1 | 1 | H | MIKE S |  | 07-026 |  | 0 | 34063.52 | 3406352 | 100 | 08-031 |  |  |  |  |  |  |
| 13643909LOEX |  | FY09 Mngmnt & Supprt Effort for PSS |  | 59d | 2008-10-01 A | 2008-12-24 A | 121642908LOE | 100% |  |  | SR STAFF [1.9 h]; ELEC DES [5.71 h]; OFFICE [5.71 h]; ELEC ENG [2.85 h] | 789.36 | 789.36 |  | 100 | 100 | 0 | 789.3431 | MAHONEY K | 1 | 1 | E | MIKE S |  |  |  |  |  |  |  |  | 08-058 |  |  |  |  |  |
| 121643115 |  | Develop Logic Specificaiton for Tagger/H-D (PSS) |  | 29d | 2008-11-10 A | 2008-12-22 A | 121643095M | 100% |  |  | ELEC ENG [80 h] | 5,138.4 | 5,138.4 |  |  |  | 0 | 5138.4 | MAHONEY K | 1 | 1 | H | MIKE S |  | 07-026 |  |  |  |  |  | 08-031 |  |  |  |  |  |  |
| 121643110 |  | Develop New Logic Specification for CEBAF Segements (PSS) |  | 85d | 2008-12-22 A | 2009-04-30 A | 121643105 FS-250d, 121643095M FS-250d | 100% |  |  | ELEC ENG [120 h] | 7,707.6 | 7,707.6 |  |  |  | 0 | 7707.6 | MAHONEY K | 1 | 1 | H | MIKE S |  | 07-026 |  |  |  |  |  | 08-031 |  |  |  |  |  |  |
| 121643100a |  | FY09 Develop PSS Detail Dsgn |  | 62d | 2009-02-02 A | 2009-04-30 A | 121643100 FS-28d | 100% | 2009-02-02 | 2009-04-29 | MECH ENG [3.16 h]; ELEC ENG [34.78 h]; ELEC TECH [9.49 h]; ELEC DES [18.97 h]; SCIENTIST [3.16 h] | 3,892.07 | 3,892.07 |  |  |  | 0 | 3892.0745 | MAHONEY K | 1 | 1 | N/A | MIKE S |  | 07-026 |  |  |  |  |  | 08-031 |  |  |  | 1.2.1.6.4.3 | EXP0809 | 09-001 |
| 121643120 |  | Develop Screen Specification (PSS) |  | 62.5d | 2009-02-02 A | 2009-04-30 A | 121643110, 121643115 | 100% |  |  | ELEC ENG [80 h] | 5,138.4 | 5,138.4 |  |  |  | 0 | 5138.4 | MAHONEY K | 1 | 1 | H | MIKE S |  | 07-026 |  |  |  |  |  | 08-031 |  |  |  |  |  |  |
| 121643125 |  | Develop PSS-EPICS Software Spec (PSS) |  | 74d | 2009-02-09 A | 2009-05-26 A | 121643110, 121643115 | 100% |  |  | COMP SCIENT [40 h]; PROCUREMENT<$50K 60; ELEC ENG [80 h] | 13,021.25 | 7,526.8 |  |  |  | 0 | 13021.25474 | MAHONEY K | 1 | 1 | H | MIKE S | 09-012 | 07-026 |  | 0 | 5494.45 | 549445 | 100 | 08-031 |  |  |  |  |  |  |
| 121643140 |  | Develop Proc Packages (PSS)++ |  | 158.5d | 2009-02-16 A | 2009-09-30 A | 121643145, 121643135 | 100% | 2009-02-17 | 2009-09-30 | ELEC ENG [200 h]; ELEC TECH [120 h]; MECH DES [40 h] | 19,420 | 19,420 |  |  |  | 0 | 19420 | MAHONEY K | 1 | 1 | H | MIKE S |  | 07-026 |  |  |  |  |  | 08-031 |  |  |  |  |  |  |
| 121643145 |  | Develop QA Documentation (PSS) |  | 53d | 2009-05-08 A | 2009-07-23 A | 121643100a FS+6d | 100% |  |  | ELEC TECH [80 h]; SR STAFF [80 h]; ELEC ENG [120 h]; ELEC DES [40 h] | 20,987.6 | 20,987.6 |  |  |  | 0 | 20987.6 | MAHONEY K | 1 | 1 | H | MIKE S |  | 07-026 |  |  |  |  |  | 08-031 |  |  |  |  |  |  |
| 121643130 |  | Comp Detail Dsgn Review - External Reviewers (PSS) |  | 75d | 2009-06-01 A | 2009-09-15 A | 121643120, 121643110, 121643125, 121643100a | 100% |  |  | ELEC TECH [80 h]; ELEC DES [80 h]; OFFICE [80 h]; SCIENTIST [40 h]; TRAVEL; ELEC ENG [160 h] | 25,118.53 | 21,817.6 |  |  |  | 0 | 25118.534591 | MAHONEY K | 1 | 1 | H | MIKE S |  | 07-026 |  |  |  |  |  | 08-031 |  |  |  |  |  |  |
| 121643135 |  | Update Dsgn Based on Review recommendations (PSS) |  | 8d | 2009-09-21 A | 2009-09-30 A | 121643130 FS-7d | 100% |  |  | ELEC TECH [40 h]; ELEC DES [80 h]; ELEC ENG [80 h] | 10,423.6 | 10,423.6 |  |  |  | 0 | 10423.6 | MAHONEY K | 1 | 1 | H | MIKE S |  | 07-026 |  |  |  |  |  | 08-031 |  |  |  |  |  |  |
| 121643170 |  | Pre-Constrctn Dsgn Review++ |  | 7.75d | 2009-09-21 A | 2009-09-30 A | 121643135 FS-110d | 100% |  |  |  |  |  |  |  |  |  | 0 | MAHONEY K | 1 | 1 | Z | MIKE S |  | 07-026 |  |  |  |  |  | 08-031 |  | C |  |  |  |  |
| 121643175 |  | Re-Baseline Actuals Adjustment |  | 1d | 2013-08-30 A | 2013-08-30 A |  | 100% | 2013-09-03 | 2013-09-03 | PROCUREMENT>$50K 69 NO ESCALATION | 25,753.46 |  |  |  |  |  | 25753.46 |  |  |  |  |  |  |  |  | 0 | 25753.46 | 2575346 | 100 |  |  |  | ADJ |  |  |  |

| ID | WBS | Activity | Type | Duration | Start | Finish | Predecessors | Complete | Planned start | Planned finish | Resources | Cost | Actual cost | Planned FinishUDF | LOE Divider | LOE Multiplier | Calculated Remaining Total Cost | MONTHLY EV COST | RESP - Responsibility | STRT%COMP for CM EVM | FNSH%COMP for CM EVM | EVMS Reporting Codes | CAM RESPONSIBLE | CR 09-012 | Milestone Level | Profile change | CR 08-058 | CR 07-027 | Claimed Material Divider | ReBaseline Actuals Adjustment | Remaining Material Cost Based on % Compl | Claimed Material Cost Based on % Complet | Initial Claimed Material Calc |
| --- | --- | --- | --- | --- | --- | --- | --- | --- | --- | --- | --- | --- | --- | --- | --- | --- | --- | --- | --- | --- | --- | --- | --- | --- | --- | --- | --- | --- | --- | --- | --- | --- | --- |
|  | 4 | **1.2.1.6.4.4** |  |  |  |  |  |  |  |  |  |  |  |  |  |  |  |  |  |  |  |  |  |  |  |  |  |  |  |  |  |  |  |
|  | 5 | **1.2.1.6.5 INSERTABLE DUMP** |  |  | 2006-10-02 | 2013-08-30 |  |  |  |  |  |  |  |  |  |  |  |  |  |  |  |  |  |  |  |  |  |  |  |  |  |  |  |
| 12165007LOE |  | FY07 Management Effort for Dump Controls (INSERT DUMP) |  | 247d | 2006-10-02 A | 2007-09-28 A | 9-070M | 100% |  |  | SCIENTIST [11.83 h]; ELEC ENG [11.48 h]; SR STAFF [11.6 h] | 2,631.56 | 2,631.56 | 2007-09-28 | 100 | 100 | 0 | 2631.555024 | GARZA O | 1 | 1 | N/A | MIKE S | 09-012 |  |  |  |  |  |  |  |  |  |
| 12165010 |  | Define & Package System Layout (INSERT DUMP) |  | 118d | 2006-11-01 A | 2007-04-27 A | 9-070M | 100% |  |  | ELEC ENG [52.2 h]; SCIENTIST [52.2 h] | 6,758.88 | 6,758.88 | 2006-11-10 |  |  | 0 | 6799.572 | GARZA O | 1 | 1 | N/A | MIKE S |  |  |  |  |  |  |  |  |  |  |
| 12165015 |  | Design Top-Level System Layout (INSERT DUMP) |  | 51d | 2007-02-15 A | 2007-04-27 A | 12165010 FS+10d | 100% |  |  | ELEC ENG [113.1 h]; SCIENTIST [26 h]; ELEC TECH [60.9 h]; ELEC DES [113.1 h] | 16,517.52 | 16,517.52 | 2007-01-18 |  |  | 0 | 16751.173 | GARZA O | 1 | 1 | N/A | MIKE S |  |  |  |  |  |  |  |  |  |  |
| 12165016 |  | Preliminary Design & Safety Review (INSERT DUMP) |  | 86d | 2007-02-22 A | 2007-06-22 A | 12165015 FS+28d | 100% |  |  | ELEC ENG [6.8 h]; COMP SCIENT [6.8 h] | 825.59 | 825.59 | 2007-03-01 |  |  | 0 | 843.132 | GARZA O | 1 | 1 | N/A | MIKE S |  |  |  |  |  |  |  |  |  |  |
| 12165016M |  | Complete Preliminary Design & Safety Review for Dump Controls (INSERT DUMP) | milestone | 0d | 2007-06-22 A | 2007-06-22 A | 12165016 | 100% | 2007-03-01 | 2007-03-01 |  |  |  | 2007-03-01 |  |  |  | 0 | GARZA O | 1 | 1 | N/A | MIKE S |  | 5 |  |  |  |  |  |  |  |  |
| 12165020M |  | Ready to Baseline Milestone for Dump Controls (INSERT DUMP) | milestone | 0d | 2007-06-22 A | 2007-06-22 A | 12165016M, 12165015 FS+29d | 100% | 2007-03-01 | 2007-03-01 |  |  |  | 2007-03-01 |  |  |  | 0 | GARZA O | 1 | 1 | N/A | MIKE S |  | 9 |  |  |  |  |  |  |  |  |
| 12165908LOE |  | FY08 Mngmnt Effort for Dump Controls |  | 248d | 2007-10-01 A | 2008-09-30 A | 12165007LOE, 9-080M | 100% |  |  | SR STAFF [80 h] | 7,972.8 | 7,972.8 |  | 100 | 100 | 0 | 7972.8 | GARZA O | 1 | 1 | N/A | MIKE S | 09-012 |  |  |  |  |  |  |  |  |  |
| 12165026 |  | FY08 Comp Dump Sys Dsgn |  | 150d | 2007-12-03 A | 2008-07-15 A | 12165020M, 9-080M | 100% | 2007-12-03 | 2008-07-14 |  |  |  |  |  |  |  | 0 | GARZA O | 1 | 1 | N/A | MIKE S |  |  |  |  |  |  |  |  |  |  |
| 12165027 |  | Pre-Constrctn Final Dsgn Review for Dump |  | 3d | 2008-07-15 A | 2008-07-18 A | 12165026 | 100% | 2008-07-15 | 2008-07-17 |  |  |  |  |  |  |  | 0 | GARZA O | 1 | 1 | Z | MIKE S |  |  | C |  |  |  |  |  |  |  |
| 1365909LOEX |  | FY09 Mngmnt Effort for Dump |  | 59d | 2008-10-01 A | 2008-12-24 A | 12165908LOE | 100% |  |  | SR STAFF [0.95 h] | 97.7 | 97.7 |  | 100 | 100 | 0 | 97.698 | GARZA O | 1 | 1 | E | MIKE S |  |  |  | 08-058 |  |  |  |  |  |  |
| 12165030 |  | Compile Dump Sys Elect Prcrmnt Packages++ |  | 159d | 2009-01-30 A | 2009-09-15 A | 12165027, 9-090M FS+60d | 100% |  |  | ELEC TECH [200 h]; ELEC ENG [560 h] | 44,002.8 | 44,002.8 |  |  |  | 0 | 44002.8 | GARZA O | 1 | 1 | H | MIKE S |  |  |  |  | 07-027 |  |  |  |  |  |
| 12165035 |  | Compile Dump Systen Mech Prcrmnt Packages++ |  | 159d | 2009-01-30 A | 2009-09-15 A | 12165027 FS-250d, 9-090M | 100% |  |  | ELEC ENG [440 h]; ELEC TECH [120 h]; SUPPLIES & MATERIALS | 34,178.36 | 33,081.6 |  |  |  | 0 | 34178.362138 | GARZA O | 1 | 1 | H | MIKE S |  |  |  |  | 07-027 |  |  |  |  |  |
| 12165040 |  | Re-Baseline Actuals Adjustment |  | 1d | 2013-08-30 A | 2013-08-30 A |  | 100% | 2013-09-03 | 2013-09-03 | PROCUREMENT>$50K 69 NO ESCALATION | -96,468.98 |  |  |  |  |  |  |  |  |  |  |  |  |  |  |  |  | 100 | ADJ |  |  |  |
|  | 6 | **1.2.1.6.6 VACUUM CONTROLS** |  |  | 2006-10-02 | 2013-08-30 |  |  |  |  |  |  |  |  |  |  |  |  |  |  |  |  |  |  |  |  |  |  |  |  |  |  |  |
| 12166007LOE |  | FY07 Management Effort for Vacuum (VAC CONT) |  | 247d | 2006-10-02 A | 2007-09-28 A | 9-070M | 100% |  |  | SR STAFF [34.8 h] | 3,466.55 | 3,466.55 | 2007-09-28 | 100 | 100 | 0 | 3466.5498 | GARZA O | 1 | 1 | N/A | MIKE S |  |  |  |  |  |  |  |  |  |  |
| 12166010 |  | Design Top Level System Layout (VAC CONT) |  | 132.5d | 2006-11-01 A | 2007-05-18 A | 9-070M FS+44d | 100% |  |  | ELEC ENG [87 h]; ELEC TECH [17.6 h] | 6,377.66 | 6,377.66 | 2007-01-12 |  |  | 0 | 6477.082 | GARZA O | 1 | 1 | N/A | MIKE S |  |  |  |  |  |  |  |  |  |  |
| 12166015 |  | Define Vacuum System Interface Requirements (VAC CONT) |  | 59.5d | 2007-02-26 A | 2007-05-18 A | 9-070M FS+44d | 100% |  |  | COMP SCIENT [34.8 h] | 2,019.45 | 2,019.45 | 2007-01-12 |  |  | 0 | 2015.616 | GARZA O | 1 | 1 | N/A | MIKE S |  |  |  |  |  |  |  |  |  |  |
| 12166020 |  | Preliminary Design & Safety Review (VAC CONT) |  | 38d | 2007-04-23 A | 2007-06-15 A | 12166015 FS+33d | 100% |  |  | ELEC ENG [6.96 h] | 432.36 | 432.36 | 2007-03-05 |  |  | 0 | 459.8472 | GARZA O | 1 | 1 | N/A | MIKE S |  |  |  |  |  |  |  |  |  |  |
| 12166020M |  | Complete Preliminary Design & Safety Review Vauum Controls (VAC CONT) | milestone | 0d | 2007-06-15 A | 2007-06-15 A | 12166020, 12166010 | 100% | 2007-03-05 | 2007-03-05 |  |  |  | 2007-03-05 |  |  |  | 0 | GARZA O | 1 | 1 | N/A | MIKE S |  | 5 |  |  |  |  |  |  |  |  |
| 12166025M |  | Ready to baseline Vauum Controls (VAC CONT) | milestone | 0d | 2007-06-15 A | 2007-06-15 A | 12166015 FS+34d, 12166020M | 100% | 2007-03-05 | 2007-03-05 |  |  |  | 2007-03-05 |  |  |  | 0 | GARZA O | 1 | 1 | N/A | MIKE S |  | 9 |  |  |  |  |  |  |  |  |
| 12166908LOE |  | FY08 Mngmnt Effort for Vac (VAC CONT) |  | 248d | 2007-10-01 A | 2008-09-30 A | 9-080M, 12167007LOE, 12166007LOE | 100% |  |  | SR STAFF [40 h] | 3,986.4 | 3,986.4 |  | 100 | 100 | 0 | 3986.4 | GARZA O | 1 | 1 | N/A | MIKE S |  |  |  |  |  |  |  |  |  |  |
| 12166026 |  | FY08 Comp Sys Dsgn (VAC CONT) |  | 193d | 2007-11-01 A | 2008-08-14 A | 12166025M, 9-080M | 100% |  |  |  |  |  |  |  |  |  | 0 | GARZA O | 1 | 1 | N/A | MIKE S |  |  |  |  |  |  |  |  |  |  |
| 12166027 |  | Pre-Constrctn Final Dsgn Review for Vac Controls |  | 10d | 2008-08-15 A | 2008-08-28 A | 12166026 | 100% |  |  |  |  |  |  |  |  |  | 0 | GARZA O | 1 | 1 | Z | MIKE S |  |  | C |  |  |  |  |  |  |  |
| 1366909LOEX |  | FY09 Mngmnt Effort for SRFand ARC Vac Controls |  | 59d | 2008-10-01 A | 2008-12-24 A | 12166908LOE | 100% |  |  | SR STAFF [0.95 h] | 97.7 | 97.7 |  | 100 | 100 | 0 | 97.698 | GARZA O | 1 | 1 | E | MIKE S |  |  |  | 08-058 |  |  |  |  |  |  |
| 12166035 |  | Compile Vac Controls Sys Elect Procurements Packages++ |  | 85d | 2009-05-15 A | 2009-09-15 A | 9-090M FS+60d, 12166027 | 100% |  |  | ELEC TECH [120 h]; SUPPLIES & MATERIALS; PROCUREMENT<$50K 60; ELEC ENG [240 h] | 30,031.93 | 20,235.6 |  |  |  | 0 | 30031.922012 | GARZA O | 1 | 1 | H | MIKE S |  |  |  |  | 07-027 | 100 |  | 0 | 6388.91 | 638891 |
| 12166040 |  | Re-Baseline Actuals Adjustment |  | 1d | 2013-08-30 A | 2013-08-30 A |  | 100% | 2013-09-03 | 2013-09-03 | PROCUREMENT>$50K 69 NO ESCALATION | 7,830.46 |  |  |  |  |  | 7830.46 |  |  |  |  |  |  |  |  |  |  | 100 | ADJ | 0 | 7830.46 | 783046 |

| ID | WBS | Activity | Type | Duration | Start | Finish | Predecessors | Complete | Planned start | Planned finish | Resources | Cost | Actual cost | Planned FinishUDF | LOE Divider | LOE Multiplier | Calculated Remaining Total Cost | MONTHLY EV COST | RESP - Responsibility | STRT%COMP for CM EVM | FNSH%COMP for CM EVM | EVMS Reporting Codes | CAM RESPONSIBLE | CR 09-012 | Milestone Level | Profile change | CR 07-027 | Remaining Material Cost Based on % Compl | Claimed Material Cost Based on % Complet | Initial Claimed Material Calc | Claimed Material Divider | ReBaseline Actuals Adjustment |
| --- | --- | --- | --- | --- | --- | --- | --- | --- | --- | --- | --- | --- | --- | --- | --- | --- | --- | --- | --- | --- | --- | --- | --- | --- | --- | --- | --- | --- | --- | --- | --- | --- |
|  | 7 | **1.2.1.6.7 MAGNET INSTRUMENTATION** |  |  | 2006-10-02 | 2013-08-30 |  |  |  |  |  |  |  |  |  |  |  |  |  |  |  |  |  |  |  |  |  |  |  |  |  |  |
| 12167007LOE |  | FY07 Management Effort for Magnet Controls (MAG INSTR) |  | 247d | 2006-10-02 A | 2007-09-28 A | 9-070M | 100% |  |  | SR STAFF [34.8 h] | 3,466.55 | 3,466.55 | 2007-09-28 | 100 | 100 | 0 | 3466.5498 | GARZA O | 1 | 1 | N/A | MIKE S | 09-012 |  |  |  |  |  |  |  |  |
| 12167010 |  | Design Top-Level Magnet Control System Layout (MAG INSTR) |  | 75.5d | 2006-11-01 A | 2007-02-28 A | 9-070M FS+44d | 100% |  |  | ELEC DES [34.8 h]; ELEC ENG [34.8 h] | 3,864.54 | 3,864.54 | 2007-01-12 |  |  | 0 | 3864.54 | GARZA O | 1 | 1 | N/A | MIKE S |  |  |  |  |  |  |  |  |  |
| 12167015 |  | Preliminary Design & Safety Review (MAG INSTR) |  | 82d | 2007-02-20 A | 2007-06-15 A | 12167010 FS+14d | 100% |  |  | ELEC ENG [6.96 h] | 441.91 | 441.91 | 2007-02-05 |  |  | 0 | 459.8472 | GARZA O | 1 | 1 | N/A | MIKE S |  |  |  |  |  |  |  |  |  |
| 12167015M |  | Complete Preliminary Design & Safety Review Magnet Controls (MAG INSTR) | milestone | 0d | 2007-06-15 A | 2007-06-15 A | 12167015 | 100% | 2007-02-05 | 2007-02-05 |  |  |  | 2007-02-05 |  |  |  | 0 | GARZA O | 1 | 1 | N/A | MIKE S |  | 5 |  |  |  |  |  |  |  |
| 12167020M |  | Ready to Baseline Magnet Controls WBS (MAG INSTR) | milestone | 0d | 2007-06-15 A | 2007-06-15 A | 12167010 FS+15d, 12167015M | 100% | 2007-02-05 | 2007-02-05 |  |  |  | 2007-02-05 |  |  |  | 0 | GARZA O | 1 | 1 | N/A | MIKE S |  | 9 |  |  |  |  |  |  |  |
| 12167026 |  | FY08 Comp Sys Dsgn (MAG INSTR) |  | 25d | 2007-12-03 A | 2008-01-15 A | 12167020M, 9-080M | 100% |  |  |  |  |  |  |  |  |  | 0 | GARZA O | 1 | 1 | N/A | MIKE S |  |  |  |  |  |  |  |  |  |
| 12167027 |  | Pre-Constrctn Final Dsgn Review for Mag Instrmenttn |  | 2.5d | 2008-02-04 A | 2008-02-06 A | 12167026 | 100% |  |  |  |  |  |  |  |  |  | 0 | GARZA O | 1 | 1 | N/A | MIKE S |  |  | C |  |  |  |  |  |  |
| 12167028 |  | Compile Mag Control Sys Elect Prcrmnt Package+ |  | 84.5d | 2009-05-15 A | 2009-09-15 A | 12167027, 9-090M FS+60d | 100% |  |  | ELEC TECH [40 h]; ELEC ENG [40 h] | 4,176 | 4,176 |  |  |  | 0 | 4176 | GARZA O | 1 | 1 | H | MIKE S |  |  |  | 07-027 |  |  |  |  |  |
| 12167030 |  | Re-Baseline Actuals Adjustment |  | 1d | 2013-08-30 A | 2013-08-30 A |  | 100% | 2013-09-03 | 2013-09-03 | PROCUREMENT>$50K 69 NO ESCALATION | 844.63 |  |  |  |  |  | 844.63 |  |  |  |  |  |  |  |  |  | 0 | 844.63 | 84463 | 100 | ADJ |
|  | 7 | **1.2.1.7** |  |  |  |  |  |  |  |  |  |  |  |  |  |  |  |  |  |  |  |  |  |  |  |  |  |  |  |  |  |  |
|  | 2 | **1.2.2 UPGRADE HALLS A, B & C** |  |  | 2006-10-02 | 2013-08-30 |  |  |  |  |  |  |  |  |  |  |  |  |  |  |  |  |  |  |  |  |  |  |  |  |  |  |
| 122030M |  | Monthly Safety Inspection Completed | milestone | 0d | 2006-10-31 A | 2006-10-31 A | 9-070M FS+22d | 100% |  |  |  |  |  | 2006-10-31 |  |  |  | 0 | BROOKS W | 1 | 1 | N/A | ROLF E |  | 4 |  |  |  |  |  |  |  |
| 122031M |  | Monthly Safety Inspection Completed | milestone | 0d | 2006-11-30 A | 2006-11-30 A | 122030M FS+20d | 100% |  |  |  |  |  | 2006-11-30 |  |  |  | 0 | BROOKS W | 1 | 1 | N/A | ROLF E |  | 4 |  |  |  |  |  |  |  |
| 122005M |  | Quarterly Safety Meeting Complete | milestone | 0d | 2006-12-22 A | 2006-12-22 A | 9-070M FS+58d | 100% |  |  |  |  |  | 2006-12-22 |  |  |  | 0 | BROOKS W | 1 | 1 | N/A | ROLF E |  | 4 |  |  |  |  |  |  |  |
| 122032M |  | Monthly Safety Inspection Completed | milestone | 0d | 2006-12-22 A | 2006-12-22 A | 122031M FS+16d | 100% |  |  |  |  |  | 2006-12-22 |  |  |  | 0 | BROOKS W | 1 | 1 | N/A | ROLF E |  | 4 |  |  |  |  |  |  |  |
| 122033M |  | Monthly Safety Inspection Completed | milestone | 0d | 2007-01-31 A | 2007-01-31 A | 122032M FS+21d | 100% |  |  |  |  |  | 2007-01-31 |  |  |  | 0 | BROOKS W | 1 | 1 | N/A | ROLF E |  | 4 |  |  |  |  |  |  |  |
| 122034M |  | Monthly Safety Inspection Completed | milestone | 0d | 2007-02-28 A | 2007-02-28 A | 122033M FS+19d | 100% |  |  |  |  |  | 2007-02-28 |  |  |  | 0 | BROOKS W | 1 | 1 | N/A | ROLF E |  | 4 |  |  |  |  |  |  |  |
| 122010M |  | Quarterly Safety Meeting Complete | milestone | 0d | 2007-03-27 A | 2007-03-27 A | 122005M FS+62d | 100% | 2007-03-30 | 2007-03-30 |  |  |  | 2007-03-30 |  |  |  | 0 | BROOKS W | 1 | 1 | N/A | ROLF E |  | 4 |  |  |  |  |  |  |  |
| 122035M |  | Monthly Safety Inspection Completed | milestone | 0d | 2007-03-27 A | 2007-03-27 A | 122034M FS+22d | 100% | 2007-03-30 | 2007-03-30 |  |  |  | 2007-03-30 |  |  |  | 0 | BROOKS W | 1 | 1 | N/A | ROLF E |  | 4 |  |  |  |  |  |  |  |
| 122036M |  | Monthly Safety Inspection Completed | milestone | 0d | 2007-04-25 A | 2007-04-25 A | 122035M FS+21d | 100% | 2007-04-30 | 2007-04-30 |  |  |  | 2007-04-30 |  |  |  | 0 | BROOKS W | 1 | 1 | N/A | ROLF E |  | 4 |  |  |  |  |  |  |  |
| 122037M |  | Monthly Safety Inspection Completed | milestone | 0d | 2007-05-31 A | 2007-05-31 A | 122036M FS+22d | 100% |  |  |  |  |  | 2007-05-31 |  |  |  | 0 | BROOKS W | 1 | 1 | N/A | ROLF E |  | 4 |  |  |  |  |  |  |  |
| 122015M |  | Quarterly Safety Meeting Complete | milestone | 0d | 2007-06-12 A | 2007-06-12 A | 122010M FS+64d | 100% | 2007-06-29 | 2007-06-29 |  |  |  | 2007-06-29 |  |  |  | 0 | BROOKS W | 1 | 1 | N/A | ROLF E |  | 4 |  |  |  |  |  |  |  |
| 122038M |  | Monthly Safety Inspection Completed | milestone | 0d | 2007-06-29 A | 2007-06-29 A | 122037M FS+21d | 100% |  |  |  |  |  | 2007-06-29 |  |  |  | 0 | BROOKS W | 1 | 1 | N/A | ROLF E |  | 4 |  |  |  |  |  |  |  |
| 122039M |  | Monthly Safety Inspection Completed | milestone | 0d | 2007-07-27 A | 2007-07-27 A | 122038M FS+21d | 100% | 2007-07-31 | 2007-07-31 |  |  |  | 2007-07-31 |  |  |  | 0 | BROOKS W | 1 | 1 | N/A | ROLF E |  | 4 |  |  |  |  |  |  |  |
| 122040M |  | Monthly Safety Inspection Completed | milestone | 0d | 2007-08-31 A | 2007-08-31 A | 122039M FS+23d | 100% | 2007-09-04 | 2007-09-04 |  |  |  | 2007-08-31 |  |  |  | 0 | BROOKS W | 1 | 1 | N/A | ROLF E |  | 4 |  |  |  |  |  |  |  |
| 122041M |  | Monthly Sfty Inspection Comptd | milestone | 0d | 2007-10-01 A | 2007-10-01 A | 122040M FS+19d | 100% | 2007-11-01 | 2007-11-01 |  |  |  | 2007-09-28 |  |  |  | 0 | BROOKS W | 1 | 1 | N/A | ROLF E |  | 6 |  |  |  |  |  |  |  |
| 122020M |  | Quarterly Sfty Meet Comp | milestone | 0d | 2007-10-16 A | 2007-10-16 A | 122015M FS+63d | 100% | 2007-11-01 | 2007-11-01 |  |  |  | 2007-09-28 |  |  |  | 0 | BROOKS W | 1 | 1 | N/A | ROLF E |  | 6 |  |  |  |  |  |  |  |

| ID | WBS | Activity | Type | Duration | Start | Finish | Predecessors | Complete | Planned start | Planned finish | Resources | Cost | Actual cost | Planned FinishUDF | MONTHLY EV COST | RESP - Responsibility | STRT%COMP for CM EVM | FNSH%COMP for CM EVM | Milestone Level | EVMS Reporting Codes | CAM RESPONSIBLE | Remaining Material Cost Based on % Compl | Claimed Material Cost Based on % Complet | Initial Claimed Material Calc | Claimed Material Divider | Calculated Remaining Total Cost | CR 09-012 | LOE Divider | LOE Multiplier | ReBaseline Actuals Adjustment |
| --- | --- | --- | --- | --- | --- | --- | --- | --- | --- | --- | --- | --- | --- | --- | --- | --- | --- | --- | --- | --- | --- | --- | --- | --- | --- | --- | --- | --- | --- | --- |
|  | 1 | **1.2.2.1 HALL A** |  |  | 2006-10-16 | 2013-08-30 |  |  |  |  |  |  |  |  |  |  |  |  |  |  |  |  |  |  |  |  |  |  |  |  |
|  | 1 | **1.2.2.1.1 MAGNET** |  |  |  |  |  |  |  |  |  |  |  |  |  |  |  |  |  |  |  |  |  |  |  |  |  |  |  |  |
|  | 1 | **1.2.2.1.1.1 COMBINED FUNCTION MAGNET** |  |  |  |  |  |  |  |  |  |  |  |  |  |  |  |  |  |  |  |  |  |  |  |  |  |  |  |  |
|  | 2 | **1.2.2.1.1.2 CRYOGENIC SYSTEM** |  |  |  |  |  |  |  |  |  |  |  |  |  |  |  |  |  |  |  |  |  |  |  |  |  |  |  |  |
|  | 3 | **1.2.2.1.1.3 POWER SUPPLY** |  |  |  |  |  |  |  |  |  |  |  |  |  |  |  |  |  |  |  |  |  |  |  |  |  |  |  |  |
|  | 4 | **1.2.2.1.1.4 SHIELD HOUSE** |  |  |  |  |  |  |  |  |  |  |  |  |  |  |  |  |  |  |  |  |  |  |  |  |  |  |  |  |
|  | 5 | **1.2.2.1.1.5 SUPPORT STRUCTURE & MOTION SYSTEM** |  |  |  |  |  |  |  |  |  |  |  |  |  |  |  |  |  |  |  |  |  |  |  |  |  |  |  |  |
|  | 6 | **1.2.2.1.1.6 CONTROL SYSTEM** |  |  |  |  |  |  |  |  |  |  |  |  |  |  |  |  |  |  |  |  |  |  |  |  |  |  |  |  |
|  | 7 | **1.2.2.1.1.7 SEPTUM** |  |  |  |  |  |  |  |  |  |  |  |  |  |  |  |  |  |  |  |  |  |  |  |  |  |  |  |  |
|  | 2 | **1.2.2.1.2 DETECTORS** |  |  |  |  |  |  |  |  |  |  |  |  |  |  |  |  |  |  |  |  |  |  |  |  |  |  |  |  |
|  | 1 | **1.2.2.1.2.1 TRIGGER SYSTEM (Scintillators)** |  |  |  |  |  |  |  |  |  |  |  |  |  |  |  |  |  |  |  |  |  |  |  |  |  |  |  |  |
|  | 2 | **1.2.2.1.2.2 TRACKING SYSTEM (Drift Chambers)** |  |  |  |  |  |  |  |  |  |  |  |  |  |  |  |  |  |  |  |  |  |  |  |  |  |  |  |  |
|  | 3 | **1.2.2.1.2.3 GAS CERENKOV** |  |  |  |  |  |  |  |  |  |  |  |  |  |  |  |  |  |  |  |  |  |  |  |  |  |  |  |  |
|  | 4 | **1.2.2.1.2.4 AREOGEL CERENKOV** |  |  |  |  |  |  |  |  |  |  |  |  |  |  |  |  |  |  |  |  |  |  |  |  |  |  |  |  |
|  | 5 | **1.2.2.1.2.5 CALORIMETER** |  |  |  |  |  |  |  |  |  |  |  |  |  |  |  |  |  |  |  |  |  |  |  |  |  |  |  |  |
|  | 6 | **1.2.2.1.2.6 FOCAL PLANE POLARIMETER** |  |  |  |  |  |  |  |  |  |  |  |  |  |  |  |  |  |  |  |  |  |  |  |  |  |  |  |  |
|  | 3 | **1.2.2.1.3 COMPUTING** |  |  | 2007-04-18 | 2013-08-30 |  |  |  |  |  |  |  |  |  |  |  |  |  |  |  |  |  |  |  |  |  |  |  |  |
|  | 1 | **1.2.2.1.3.1 DAQ FOR MAD** |  |  |  |  |  |  |  |  |  |  |  |  |  |  |  |  |  |  |  |  |  |  |  |  |  |  |  |  |
|  | 2 | **1.2.2.1.3.2 DAQ UPGRADES FOR HRS** |  |  | 2007-04-18 | 2013-08-30 |  |  |  |  |  |  |  |  |  |  |  |  |  |  |  |  |  |  |  |  |  |  |  |  |
| 122132005M |  | Start PED DAQ upgrade for one HRS (DAQ UPGRD) | milestone | 0d | 2007-04-18 A | 2007-04-18 A | 9-070M | 100% | 2006-10-02 | 2006-10-02 |  |  |  | 2006-10-02 | 0 | LEROSE J | 1 | 1 | 9 | N/A | JOHN L |  |  |  |  |  |  |  |  |  |
| 122132010 |  | Specify readout modules & busses trigger changes. Design power dist changes. Engineer DAQ driver changes (DAQ UPGRD) |  | 112d | 2007-04-18 A | 2007-09-25 A | 122132005M | 100% |  |  | ELEC DES [40 h]; PROCUREMENT<$50K 60; SCIENTIST [416 h]; ELEC ENG [40 h] | 45,407.29 | 29,927.29 | 2007-02-08 | 46625.04 | LEROSE J | 1 | 1 |  | N/A | JOHN L | 0 | 15480 | 1548000 | 100 | 0 | 09-012 |  |  |  |
| 122132908LOE |  | FY08 Proj Admin H-A |  | 248d | 2007-10-01 A | 2008-09-30 A | 1252007LOE, 9-080M | 100% |  |  | SCIENTIST [88 h] | 5,479.76 | 5,479.76 |  | 5479.76 | LEROSE J | 1 | 1 |  | N/A | JOHN L |  |  |  |  | 0 |  | 100 | 100 |  |
| 122132015 |  | Re-Baseline Actuals Adjustment |  | 1d | 2013-08-30 A | 2013-08-30 A |  | 100% | 2013-09-03 | 2013-09-03 | PROCUREMENT>$50K 69 NO ESCALATION | 10,124 |  |  | 10124 |  |  |  |  |  |  | 0 | 10124 | 1012400 | 100 |  |  |  |  | ADJ |
|  | 4 | **1.2.2.1.4 FAST ELECTRONICS** |  |  |  |  |  |  |  |  |  |  |  |  |  |  |  |  |  |  |  |  |  |  |  |  |  |  |  |  |
|  | 5 | **1.2.2.1.5 BEAMLINE** |  |  | 2006-10-16 | 2013-08-30 |  |  |  |  |  |  |  |  |  |  |  |  |  |  |  |  |  |  |  |  |  |  |  |  |
|  | 1 | **1.2.2.1.5.1 MOLLER POLARIMETER UPGRADE** |  |  | 2006-10-16 | 2013-08-30 |  |  |  |  |  |  |  |  |  |  |  |  |  |  |  |  |  |  |  |  |  |  |  |  |
| 122151005M |  | Start PED Moller (MLLR PLRMTR UPGRD) | milestone | 0d | 2006-10-16 A | 2006-10-16 A | 9-070M | 100% | 2006-10-02 | 2006-10-02 |  |  |  | 2006-10-02 | 0 | LEROSE J | 1 | 1 | 9 | N/A | JOHN L |  |  |  |  |  |  |  |  |  |
| 122151010 |  | Design dipole/detector stands beamline changes dipole insert (MLLR PLRMTR UPGRD) |  | 88d | 2006-10-16 A | 2007-02-28 A | 122151005M | 100% |  |  | ELEC DES [40 h]; PLABOR; SCIENTIST [160 h]; VISTNG USERS [160 h]; MECH DES [240 h] | 27,052.4 | 25,462.4 | 2007-02-08 | 27052.4 | LEROSE J | 1 | 1 |  | N/A | JOHN L |  |  |  |  | 0 |  |  |  |  |
| 122151015 |  | Re-Baseline Actuals Adjustment |  | 1d | 2013-08-30 A | 2013-08-30 A |  | 100% | 2013-09-03 | 2013-09-03 | PROCUREMENT>$50K 69 NO ESCALATION | -10,167.15 |  |  |  |  |  |  |  |  |  |  |  |  | 100 |  |  |  |  | ADJ |

| ID | WBS | Activity | Type | Duration | Start | Finish | Predecessors | Complete | Planned start | Planned finish | Resources | Cost | Actual cost | Planned FinishUDF | MONTHLY EV COST | RESP - Responsibility | STRT%COMP for CM EVM | FNSH%COMP for CM EVM | Milestone Level | EVMS Reporting Codes | CAM RESPONSIBLE | Calculated Remaining Total Cost | CR 07-027 | Remaining Material Cost Based on % Compl | Claimed Material Cost Based on % Complet | Initial Claimed Material Calc | Claimed Material Divider | ReBaseline Actuals Adjustment | CR 08-010 | CR 09-012 | LOE Divider | LOE Multiplier | CR 07-002 | CR 07-012 | 12 GeV 4th level Critical Path | CR 07-024 | CR 07-025 | CR 08-011 | Activities with Steps | CR 11-026 | CR 11-022 | CR 08-058 | CR 11-035 | CR 11-005 |
| --- | --- | --- | --- | --- | --- | --- | --- | --- | --- | --- | --- | --- | --- | --- | --- | --- | --- | --- | --- | --- | --- | --- | --- | --- | --- | --- | --- | --- | --- | --- | --- | --- | --- | --- | --- | --- | --- | --- | --- | --- | --- | --- | --- | --- |
|  | 2 | **1.2.2.1.5.2 COMPTON POLARIMETER UPGRADE** |  |  | 2006-10-16 | 2013-08-30 |  |  |  |  |  |  |  |  |  |  |  |  |  |  |  |  |  |  |  |  |  |  |  |  |  |  |  |  |  |  |  |  |  |  |  |  |  |  |
| 122152005M |  | Start FY07 PED Compton - 1st phase | milestone | 0d | 2006-10-16 A | 2006-10-16 A | 9-070M FS+98d | 100% | 2007-03-01 | 2007-03-01 |  |  |  | 2007-03-01 | 0 | LEROSE J | 1 | 1 | 9 | N/A | JOHN L |  |  |  |  |  |  |  |  |  |  |  |  |  |  |  |  |  |  |  |  |  |  |  |
| 122152010 |  | FY07 Design magnets / cavity stands. Engineer detector mods (COMPT PLRMTR UPGRD) |  | 234d | 2006-10-16 A | 2007-09-25 A | 122152005M | 100% |  |  | SCIENTIST [160 h]; PD UNIV STUDNT [400 h]; MECH ENG [80 h]; MECH DES [120 h] | 24,070.25 | 24,070.25 | 2007-06-28 | 24340.625882 | LEROSE J | 1 | 1 |  | N/A | JOHN L | 0 |  |  |  |  |  |  |  |  |  |  |  |  |  |  |  |  |  |  |  |  |  |  |
| 122152015M |  | Start FY08 Milestone P-#2 (COMPT PLRMTR UPGRD) | milestone | 0d | 2007-11-01 A | 2007-11-01 A | 122151010, 122020M, 122152010, 122132010, 122041M, 9-080M FS+185d | 100% | 2008-07-02 | 2008-07-02 |  |  |  |  | 0 | LEROSE J | 1 | 1 | 6 | N/A | JOHN L |  | 07-027 |  |  |  |  |  |  |  |  |  |  |  |  |  |  |  |  |  |  |  |  |  |
| 122152020 |  | FY08 Dsgn Vac Pipe & Detector motion Sys (COMPT PLRMTR UPGRD)+ |  | 496d | 2007-11-01 A | 2009-11-02 A | 122152015M | 100% |  |  | MECH ENG [80 h]; MECH DES [120 h]; SCIENTIST [160 h]; PD UNIV STUDNT [400 h] | 24,223.12 | 24,223.12 |  | 23772 | LEROSE J | 1 | 1 |  | N/A | JOHN L | 0 | 07-027 |  |  |  |  |  |  |  |  |  |  |  |  |  |  |  |  |  |  |  |  |  |
| 122152025 |  | Re-Baseline Actuals Adjustment |  | 1d | 2013-08-30 A | 2013-08-30 A |  | 100% | 2013-09-03 | 2013-09-03 | PROCUREMENT>$50K 69 NO ESCALATION | 27,306.32 |  |  | 27306.32 |  |  |  |  |  |  |  |  | 0 | 27306.32 | 2730632 | 100 | ADJ |  |  |  |  |  |  |  |  |  |  |  |  |  |  |  |  |
|  | 3 | **1.2.2.1.5.3 MAPPING-ARC ENERGY MEASUREMENT** |  |  | 2007-09-04 | 2013-08-30 |  |  |  |  |  |  |  |  |  |  |  |  |  |  |  |  |  |  |  |  |  |  |  |  |  |  |  |  |  |  |  |  |  |  |  |  |  |  |
| 122153000M |  | Start FY07 PED 9th dipole mapper 1ST Phase | milestone | 0d | 2007-09-04 A | 2007-09-04 A | 9-070M | 100% | 2007-10-01 | 2007-10-01 |  |  |  | 2007-03-13 | 0 | LEROSE J | 1 | 1 | 9 | N/A | JOHN L |  |  |  |  |  |  |  |  |  |  |  |  |  |  |  |  |  |  |  |  |  |  |  |
| 122153005 |  | FY07 PED Engineer & analysis of mapping coil 1st Phase |  | 16d | 2007-09-04 A | 2007-09-25 A | 122153000M | 100% |  |  | SUPPLIES & MATERIALS; SCIENTIST [96.8 h]; MECH ENG [77.6 h]; ELEC ENG [19.2 h]; TRAVEL; ELEC DES [19.2 h]; MECH DES [155.2 h] | 23,478.77 | 18,868.77 | 2007-06-05 | 24628.344 | LEROSE J | 1 | 1 |  | N/A | JOHN L | 0 | 07-027 |  |  |  |  |  |  |  |  |  |  |  |  |  |  |  |  |  |  |  |  |  |
| 122153009M |  | Start FY09 PED 9th Dipole Mapper P-#2 | milestone | 0d | 2008-07-07 A | 2008-07-07 A | 9-090M, 122153005 | 100% | 2008-10-01 | 2008-10-01 |  |  |  |  | 0 | LEROSE J | 1 | 1 | 6 | M | JOHN L |  | 07-027 |  |  |  |  |  |  |  |  |  |  |  |  |  |  |  |  |  |  |  |  |  |
| 122153010 |  | FY08 PED Mech & Elect Sys Dsgn P-2+ |  | 6d | 2008-07-07 A | 2008-07-14 A | 122153009M FS+105d | 100% |  |  | MECH DES [40 h] | 1,699.2 | 1,699.2 |  | 1753.6 | LEROSE J | 1 | 1 |  | H | JOHN L | 0 | 07-027 |  |  |  |  |  | 08-010 | 09-012 |  |  |  |  |  |  |  |  |  |  |  |  |  |  |
| 122153015 |  | Re-Baseline Actuals Adjustment |  | 1d | 2013-08-30 A | 2013-08-30 A |  | 100% | 2013-09-03 | 2013-09-03 | PROCUREMENT>$50K 69 NO ESCALATION | -25,126.01 |  |  |  |  |  |  |  |  |  |  |  |  |  |  | 100 | ADJ |  |  |  |  |  |  |  |  |  |  |  |  |  |  |  |  |
|  | 6 | **1.2.2.1.6 INFRASTRUCTURE** |  |  |  |  |  |  |  |  |  |  |  |  |  |  |  |  |  |  |  |  |  |  |  |  |  |  |  |  |  |  |  |  |  |  |  |  |  |  |  |  |  |  |
|  | 1 | **1.2.2.1.6.1 ENGINEERING & DESIGN** |  |  |  |  |  |  |  |  |  |  |  |  |  |  |  |  |  |  |  |  |  |  |  |  |  |  |  |  |  |  |  |  |  |  |  |  |  |  |  |  |  |  |
|  | 2 | **1.2.2.1.6.2 CABLING** |  |  |  |  |  |  |  |  |  |  |  |  |  |  |  |  |  |  |  |  |  |  |  |  |  |  |  |  |  |  |  |  |  |  |  |  |  |  |  |  |  |  |
|  | 3 | **1.2.2.1.6.3 INSTALLATION** |  |  |  |  |  |  |  |  |  |  |  |  |  |  |  |  |  |  |  |  |  |  |  |  |  |  |  |  |  |  |  |  |  |  |  |  |  |  |  |  |  |  |
|  | 2 | **1.2.2.2 HALL B** |  |  | 2006-10-02 | 2013-08-30 |  |  |  |  |  |  |  |  |  |  |  |  |  |  |  |  |  |  |  |  |  |  |  |  |  |  |  |  |  |  |  |  |  |  |  |  |  |  |
|  | 1 | **1.2.2.2.1 MAGNET** |  |  | 2006-10-02 | 2013-08-30 |  |  |  |  |  |  |  |  |  |  |  |  |  |  |  |  |  |  |  |  |  |  |  |  |  |  |  |  |  |  |  |  |  |  |  |  |  |  |
| 122211007LOE |  | FY07 Project Management for all Hall B |  | 247d | 2006-10-02 A | 2007-09-28 A | 9-070M | 100% |  |  | SCIENTIST [520 h] | 32,781.24 | 32,781.24 | 2007-09-28 | 32781.239368 | ELOUADRHIRI L | 1 | 1 |  | N/A | LATIFA E | 0 |  |  |  |  |  |  |  | 09-012 | 100 | 100 | 07-002 | 07-012 |  |  |  |  |  |  |  |  |  |  |
| 122211015M |  | Torus- Completion of ACD technical review and summary report | milestone | 0d | 2007-04-26 A | 2007-04-26 A | 9-070M FS+139d | 100% |  |  |  |  |  | 2007-04-26 | 0 | ELOUADRHIRI L | 1 | 1 | 5 | N/A | LATIFA E |  |  |  |  |  |  |  |  |  |  |  | 07-002 | 07-012 | 4 |  |  |  |  |  |  |  |  |  |
| 122212015M |  | Sol- Completion of ACD technical review and progress report | milestone | 0d | 2007-04-26 A | 2007-04-26 A | 9-070M FS+139d | 100% |  |  |  |  |  | 2007-04-26 | 0 | ELOUADRHIRI L | 1 | 1 | 5 | N/A | LATIFA E |  |  |  |  |  |  |  |  |  |  |  | 07-002 | 07-012 |  |  |  |  |  |  |  |  |  |  |
| 122211020 |  | Torus- First phase of the design (TOROIDAL MAG) |  | 77d | 2007-04-27 A | 2007-08-15 A | 122211017, 122211015M | 100% |  |  | MECH DES [252 h]; PROCUREMENT<$50K 60; PROCUREMENT>$50K 69; MECH ENG [160 h] | 62,928.07 | 20,538.07 | 2007-07-31 | 62656.212 | ELOUADRHIRI L | 1 | 1 |  | N/A | LATIFA E | 0 |  | 0 | 42390 | 4239000 | 100 |  |  |  |  |  | 07-002 | 07-012 | 4 | 07-024 |  |  |  |  |  |  |  |  |
| 122212017 |  | Sol- Initial Payment for the design (SACLAY) |  | 271d | 2007-04-27 A | 2008-05-30 A | 122212015M | 100% |  |  | PROCUREMENT<$50K 60; PROCUREMENT>$50K 69 | 78,790 |  | 2007-04-27 | 78790 | ELOUADRHIRI L | 1 | 1 |  | N/A | LATIFA E | 0 | 07-027 | 0 | 78790 | 7879000 | 100 |  |  |  |  |  | 07-002 | 07-012 |  |  | 07-025 |  |  |  |  |  |  |  |
| 122212020 |  | Sol- First phase of the design (SOLENOID) |  | 77d | 2007-04-27 A | 2007-08-15 A | 122212017 | 100% |  |  | PROCUREMENT<$50K 60; MECH ENG [28.4 h]; MECH DES [44 h]; PROCUREMENT>$50K 69 | 39,024.36 | 3,614.36 | 2007-07-31 | 38976.623009 | ELOUADRHIRI L | 1 | 1 |  | N/A | LATIFA E | 0 | 07-027 | 0 | 35410 | 3541000 | 100 |  |  |  |  |  | 07-002 | 07-012 |  |  |  |  |  |  |  |  |  |  |
| 122211025M |  | Torus- Safety Assessment (TOROIDAL MAG) | milestone | 0d | 2007-08-15 A | 2007-08-15 A | 122211020 | 100% | 2007-10-03 | 2007-10-03 |  |  |  |  | 0 | ELOUADRHIRI L | 1 | 1 | 5 | N/A | LATIFA E |  | 07-027 |  |  |  |  |  |  |  |  |  | 07-002 | 07-012 | 4 |  |  |  |  |  |  |  |  |  |
| 122212025M |  | Sol- Safety Assessment (SOLENOID) | milestone | 0d | 2007-08-15 A | 2007-08-15 A | 122212020 | 100% | 2007-10-03 | 2007-10-03 |  |  |  | 2007-07-31 | 0 | ELOUADRHIRI L | 1 | 1 | 5 | N/A | LATIFA E |  | 07-027 |  |  |  |  |  |  |  |  |  | 07-002 | 07-012 |  |  |  |  |  |  |  |  |  |  |
| 12221040 |  | **Torus Labor Reference Dsgn |  | 131.5d | 2007-11-01 A | 2008-05-19 A | 122211036M FS-10d | 100% |  |  | MECH ENG [40 h]; SR STAFF [100 h]; TRAVEL; MECH DES [40 h] | 21,362.1 | 14,138.8 |  | 21362.1 | ELOUADRHIRI L | 1 | 1 |  | N/A | LATIFA E | 0 |  |  |  |  |  |  |  | 09-012 |  |  |  |  | 4 | 07-024 |  | 08-011 |  |  |  |  |  |  |
| 122211017 |  | Torus- Initial Payment for the design (TOROIDAL MAG) |  | 1d | 2007-11-01 A | 2007-11-01 A | 122211015M | 100% |  |  |  |  |  | 2007-04-27 | 0 | ELOUADRHIRI L | 1 | 1 |  | N/A | LATIFA E |  | 07-027 |  |  |  |  |  |  | 09-012 |  |  | 07-002 | 07-012 | 4 |  | 07-025 |  |  |  |  |  |  |  |
| 122211035 |  | **Torus-FY07-Contract for Design (1st & part 2nd prog pymnt) |  | 44d | 2007-11-01 A | 2008-01-15 A | 1131005, 122211036M | 100% | 2007-11-01 | 2008-01-14 | MECH ENG [92 h]; PROCUREMENT<$50K 60 NO ESCALATION FY08; PROCUREMENT>$50K 69 NO ESCALATION FY08; MECH DES [184 h] | 48,915.6 | 13,505.6 | 2007-09-28 | 48728.14908 | ELOUADRHIRI L | 1 | 1 |  | N/A | LATIFA E | 0 | 07-027 | 0 | 35410 | 3541000 | 100 |  |  | 09-012 |  |  | 07-002 | 07-012 | 4 | 07-024 |  | 08-011 |  |  |  |  |  |  |
| 122211036M |  | Torus- Contract Award | milestone | 0d | 2007-11-01 A | 2007-11-01 A | 9-080M FS+23d | 100% | 2007-12-03 | 2007-12-03 |  |  |  | 2007-04-26 | 0 | ELOUADRHIRI L | 1 | 1 | 5 | N/A | LATIFA E |  |  |  |  |  |  |  |  |  |  |  | 07-002 | 07-012 | 4 |  |  | 08-011 |  |  |  |  |  |  |
| 122211037S |  | **Torus- Contract for Design (balance of 2nd & 3rd progress pymnts) |  | 119d | 2007-11-01 A | 2008-04-30 A | 122211035M FS+1d, 122211036M | 100% |  |  | PROCUREMENT>$50K 69; PROCUREMENT<$50K 60 | 64,597.97 |  | 2007-04-27 | 64597.97 | ELOUADRHIRI L | 1 | 1 |  | N/A | LATIFA E | 0 | 07-027 | 0 | 64597.97 | 6459797 | 100 |  |  |  |  |  | 07-002 |  |  |  |  | 08-011 |  |  |  |  |  |  |
| 122212035 |  | **Solenoid- FY07 Contract for Design (1st & part 2nd prog pymnt) |  | 86d | 2007-11-01 A | 2008-03-14 A | 122212036M | 100% |  |  | MECH DES [28 h]; MECH ENG [12 h]; PROCUREMENT<$50K 60 NO ESCALATION FY08; PROCUREMENT>$50K 69 NO ESCALATION FY08 | 37,341.52 | 1,931.52 | 2007-09-28 | 37285.085642 | ELOUADRHIRI L | 1 | 1 |  | N/A | LATIFA E | 0 | 07-027 | 0 | 35410 | 3541000 | 100 |  |  | 09-012 |  |  | 07-002 | 07-012 |  | 07-024 |  | 08-011 |  |  |  |  |  |  |
| 122212036M |  | Solenoid- Contract Award | milestone | 0d | 2007-11-01 A | 2007-11-01 A | 9-080M FS+23d | 100% | 2007-12-03 | 2007-12-03 |  |  |  | 2007-04-26 | 0 | ELOUADRHIRI L | 1 | 1 | 5 | N/A | LATIFA E |  |  |  |  |  |  |  |  |  |  |  | 07-002 | 07-012 | 4 |  |  | 08-011 |  |  |  |  |  |  |
| 122212037S |  | **Solenoid- Contract for Design (balance of 2nd & 3rd progress pymnts) |  | 118.38d | 2007-11-01 A | 2008-04-30 A | 122212036M | 100% |  |  | PROCUREMENT>$50K 69 | 49,247.28 |  | 2007-04-27 | 49247.283034 | ELOUADRHIRI L | 1 | 1 |  | N/A | LATIFA E | 0 | 07-027 | 0 | 49247.28 | 4924728 | 100 |  |  | 09-012 |  |  | 07-002 |  |  |  |  | 08-011 | ST |  |  |  |  |  |
| 12221055 |  | **Solenoid Labor Reference Dsgn |  | 322.08d | 2007-11-01 A | 2009-03-02 A | 122212036M FS-11d | 100% | 2007-11-01 | 2009-02-27 | MECH ENG [40 h]; SR STAFF [100 h]; MECH DES [40 h] | 14,276.09 | 14,276.09 |  | 14138.8 | ELOUADRHIRI L | 1 | 1 |  | N/A | LATIFA E | 0 |  |  |  |  |  |  |  | 09-012 |  |  |  |  |  | 07-024 |  | 08-011 |  |  |  |  |  |  |
| 122211038M |  | Torus- 1st Progress Payment Completed | milestone | 0d | 2007-12-14 A | 2007-12-14 A | 122211036M FS+19d, 122211035 FS-5d | 100% | 2008-01-09 | 2008-01-09 |  |  |  | 2007-04-26 | 0 | ELOUADRHIRI L | 1 | 1 | 5 | N/A | LATIFA E |  |  |  |  |  |  |  |  |  |  |  | 07-002 | 07-012 | 4 |  |  | 08-011 |  |  |  |  |  |  |
| 122211035M |  | Torus- FY07 Techncl Dsgn Report & Sfty Assessmnt | milestone | 0d | 2007-12-14 A | 2007-12-14 A | 122211035 | 100% | 2008-01-15 | 2008-01-15 |  |  |  | 2007-07-31 | 0 | ELOUADRHIRI L | 1 | 1 | 6 | N/A | LATIFA E |  |  |  |  |  |  |  |  |  |  |  | 07-002 | 07-012 | 4 |  |  |  |  |  |  |  |  |  |
| 122211039M |  | Torus- 2nd Progress Payment Completed | milestone | 0d | 2008-01-15 A | 2008-01-15 A | 122211035, 122211038M FS+16d | 100% | 2008-02-14 | 2008-02-14 |  |  |  | 2007-04-26 | 0 | ELOUADRHIRI L | 1 | 1 | 5 | N/A | LATIFA E |  |  |  |  |  |  |  |  |  |  |  | 07-002 | 07-012 | 4 |  |  | 08-011 |  |  |  |  |  |  |
| 122212038M |  | Solenoid- 1st Progress Payment Completed | milestone | 0d | 2008-01-15 A | 2008-01-15 A | 122212036M FS+38d, 122212035 | 100% | 2008-02-14 | 2008-02-14 |  |  |  | 2007-04-26 | 0 | ELOUADRHIRI L | 1 | 1 | 5 | N/A | LATIFA E |  |  |  |  |  |  |  |  |  |  |  | 07-002 | 07-012 | 4 |  |  | 08-011 |  |  |  |  |  |  |
| 12221050M |  | Solenoid- FY07 Techncl Dsgn Report & Sfty Assessmnt | milestone | 0d | 2008-02-01 A | 2008-02-01 A | 12221050 | 100% | 2008-04-01 | 2008-04-01 |  |  |  |  | 0 | ELOUADRHIRI L | 1 | 1 | 6 | N/A | LATIFA E |  |  |  |  |  |  |  |  |  |  |  |  |  |  |  |  |  |  |  |  |  |  |  |
| 122212039M |  | Solenoid- 2nd Progress Payment Completed | milestone | 0d | 2008-03-17 A | 2008-03-17 A | 122212035, 122212038M FS+38d, 12221050 | 100% | 2008-04-30 | 2008-04-30 |  |  |  | 2007-04-26 | 0 | ELOUADRHIRI L | 1 | 1 | 5 | N/A | LATIFA E |  |  |  |  |  |  |  |  |  |  |  | 07-002 | 07-012 | 4 |  |  | 08-011 |  |  |  |  |  |  |
| 12221045M |  | Torus- Reference Dsgn Comptd++ | milestone | 0d | 2008-04-04 A | 2008-04-04 A | 122211040M, 12221040, 122211025M | 100% | 2008-05-21 | 2008-05-21 |  |  |  |  | 0 | ELOUADRHIRI L | 1 | 1 | 6 | M | LATIFA E |  |  |  |  |  |  |  |  |  |  |  |  |  | 4 |  |  | 08-011 |  |  |  |  |  |  |
| 12221050 |  | **Solenoid- FY08 Contract for Design (part 2nd prog pymnt) |  | 0.92d | 2008-04-30 A | 2008-04-30 A | 122212035 | 100% |  |  | MECH DES [12 h]; MECH ENG [28 h]; PROCUREMENT<$50K 60 | 17,565 | 2,241.28 |  | 17564.995 | ELOUADRHIRI L | 1 | 1 |  | H | LATIFA E | 0 |  | 0 | 15323.72 | 1532372 | 100 |  |  |  |  |  |  |  |  |  |  | 08-011 |  |  |  |  |  |  |
| 12221060M |  | Solenoid- Reference Dsgn Comptd++ | milestone | 0d | 2008-04-30 A | 2008-04-30 A | 122212025M, 122212040M, 12221055 | 100% | 2008-05-16 | 2008-05-16 |  |  |  |  | 0 | ELOUADRHIRI L | 1 | 1 | 6 | M | LATIFA E |  |  |  |  |  |  |  |  |  |  |  |  |  |  |  |  | 08-011 |  |  |  |  |  |  |
| 122212040M |  | Solenoid- 3rd Progress Payment Completed | milestone | 0d | 2008-04-30 A | 2008-04-30 A | 122212039M, 122212037S | 100% | 2008-05-16 | 2008-05-16 |  |  |  | 2007-04-26 | 0 | ELOUADRHIRI L | 1 | 1 | 5 | M | LATIFA E |  |  |  |  |  |  |  |  |  |  |  | 07-002 | 07-012 | 4 |  |  | 08-011 |  |  |  |  |  |  |
| 122211040M |  | Torus- 3rd Progress Payment Completed | milestone | 0d | 2008-04-30 A | 2008-04-30 A | 122211037S, 122211039M | 100% | 2008-05-21 | 2008-05-21 |  |  |  | 2007-04-26 | 0 | ELOUADRHIRI L | 1 | 1 | 5 | M | LATIFA E |  |  |  |  |  |  |  |  |  |  |  | 07-002 | 07-012 | 4 |  |  | 08-011 |  |  |  |  |  |  |
| 12221045 |  | Torus Labor Procurement Prep |  | 64d | 2008-06-02 A | 2008-08-29 A | 12221040 | 100% |  |  | MECH DES [40 h]; SR STAFF [100 h]; MSHOP; TRAVEL; MECH ENG [40 h] | 26,521.6 | 14,138.8 |  | 26521.6 | ELOUADRHIRI L | 1 | 1 |  | H | LATIFA E | 0 |  |  |  |  |  |  |  | 09-012 |  |  |  |  | 4 | 07-024 |  | 08-011 |  | 11-026 |  |  |  |  |
| 12221060 |  | Solenoid Labor Procurement Prep |  | 64d | 2008-06-02 A | 2008-08-29 A | 12221055 | 100% |  |  | MECH ENG [40 h]; MECH DES [40 h]; SR STAFF [100 h]; MSHOP | 18,503.74 | 14,138.8 |  | 18503.737 | ELOUADRHIRI L | 1 | 1 |  | H | LATIFA E | 0 |  |  |  |  |  |  |  | 09-012 |  |  |  |  |  | 07-024 |  | 08-011 |  | 11-026 | 11-022 |  |  |  |
| 14211000MX |  | Torus Start 2nd Phase of Proc Prep | milestone | 0d | 2008-10-01 A | 2008-10-01 A | 12221045M, 9-090M, 12221045 | 100% | 2008-11-03 | 2008-11-03 |  |  |  |  | 0 | ELOUADRHIRI L | 1 | 1 | 6 | M | LATIFA E |  |  |  |  |  |  |  |  |  |  |  |  |  | 4 |  |  |  |  | 11-026 |  | 08-058 | 11 -035 |  |
| 14212000MX |  | Solenoid Start 2nd Phase of Proc Prep | milestone | 0d | 2008-10-01 A | 2008-10-01 A | 9-090M, 12221060 | 100% | 2008-11-03 | 2008-11-03 |  |  |  |  | 0 | ELOUADRHIRI L | 1 | 1 | 6 | M | LATIFA E |  |  |  |  |  |  |  |  |  |  |  |  |  |  |  |  |  |  | 11-026 | 11-022 | 08-058 | 11 -035 |  |
| 14211002X |  | Torus Prcrmnt Prep |  | 208d | 2008-11-03 A | 2009-09-04 A | 14211000MX | 100% |  |  | MECH TECH [800 h]; ELEC ENG [200 h]; ELEC TECH [80 h]; SCIENTIST [280 h]; OFFICE [80 h]; ELEC DES [280 h]; MECH ENG [360 h]; MECH DES [240 h] | 114,858.4 | 114,858.4 |  | 114858.4 | ELOUADRHIRI L | 1 | 1 |  | S | LATIFA E | 0 |  |  |  |  |  |  |  |  |  |  |  |  |  |  |  |  | ST | 11-026 |  | 08-058 | 11 -035 |  |
| 14211009EX |  | Torus FY09 Travel |  | 16d | 2008-12-01 A | 2008-12-22 A | 9-090M | 100% |  |  | TRAVEL | 1,899.92 |  |  | 1899.923961 | ELOUADRHIRI L | 1 | 1 |  | E | LATIFA E | 0 |  |  |  |  |  |  |  |  | 100 | 100 |  |  |  | 07-024 |  |  |  |  |  | 08-058 |  |  |
| 14212002X |  | Solenoid Prcrmnt Prep for Dsgn & Prcrmnt |  | 215d | 2008-12-01 A | 2009-10-12 A | 14212000MX, 12221060M | 100% |  |  | ELEC ENG [20 h]; ELEC TECH [60 h]; VISTNG USERS [160 h]; SCIENTIST [40 h]; OFFICE [80 h]; MECH ENG [200 h]; MECH DES [200 h]; MECH TECH [800 h] | 65,125.23 | 65,125.23 |  | 65048 | ELOUADRHIRI L | 1 | 1 |  | S | LATIFA E | 0 |  |  |  |  |  |  |  |  |  |  |  |  |  |  |  |  | ST | 11-026 | 11-022 | 08-058 | 11 -035 |  |
| 14212009EX |  | Solenoid FY09 Travel |  | 16d | 2008-12-01 A | 2008-12-22 A | 9-090M | 100% |  |  | TRAVEL | 1,899.92 |  |  | 1899.923961 | ELOUADRHIRI L | 1 | 1 |  | E | LATIFA E | 0 |  |  |  |  |  |  |  |  | 100 | 100 |  |  |  | 07-024 |  |  |  | 11-026 |  | 08-058 | 11 -035 | 11-005 |
| 122212050 |  | Re-Baseline Actuals Adjustment |  | 1d | 2013-08-30 A | 2013-08-30 A |  | 100% | 2013-09-03 | 2013-09-03 | PROCUREMENT>$50K 69 NO ESCALATION | 57,340.69 |  |  | 57340.69 |  |  |  |  |  |  |  |  | 0 | 57340.69 | 5734069 | 100 | ADJ |  |  |  |  |  |  |  |  |  |  |  |  |  |  |  |  |

Notes:
- 122211020: Corrective Actions: Reduced Over 50k Budget From $20,990 / To $18,740. Per Lyn Wells To Comply With CR 07-012. (PMC)
- 122212017: Corrective Actions: Reduced Over 50k Budget From $20,980 / To $18,735. Per Lyn Wells To Comply With CR 07-012. (PMC)
- 122212020: Corrective Actions: Reduced Over 50k Budget From $20,990 / To $18,740. Per Lyn Wells To Comply With CR 07-012. (PMC)
- 122211017: Corrective Actions: Reduced Over 50k Budget From $20,980 / To $18,735. Per Lyn Wells To Comply With CR 07-012. (PMC)
- 122211035: Corrective Actions: Reduced Over 50k Budget From $20,990 / To $18,740. Per Lyn Wells To Comply With CR 07-012. (PMC) / Explanation: Since this is an FY07 past history activity it can't be changed, so the / budget of this activity is considered to be the 1st PP ($30,002) and part of the / 2nd ($5,408 of total of $30,002 = 18.0% of the 2nd PP and 5.4% of / total Torus Contract) progress payments on the Torus / contract.
- 122211037S: Corrective Actions: Reduced Over 50k Budget From $20,980 / To $18,735. Per Lyn Wells To Comply With CR 07-012. (PMC) / Steps: Balance of 2nd PP for Approved Torus Interim Design Report (done); 3rd PP for Approved Torus Final Reference Design Study (done)
- 122212035: Corrective Actions: Reduced Over 50k Budget From $20,990 / To $18,740. Per Lyn Wells To Comply With CR 07-012. (PMC) / Explanation: Since this is an FY07 past / history activity it can't be changed, so the budget of this activity is / considered to be the 1st PP ($29,994) and part of the 2nd ($5,416 of total of / $29,994 = 18.1% of the 2nd PP and 5.4% of total Solenoid contract) progress / payments on the Solenoid contract.
- 122212037S: Corrective Actions: Reduced Over 50k Budget From $20,980 / To $18,735. Per Lyn Wells To Comply With CR 07-012. (PMC) / Steps: Balance of 2nd PP Solenoid Interim Design Report Approved (done); 3rd PP Solenoid Final Reference Design Study Approved (3rd PP = 60% of this act = 40% of Solenoid Contract) (done)
- 12221050: Explanation: Since this is an FY07 past history activity it can't be changed, so the / budget of this activity is considered to be part of the 2nd ($14,850 of / total of $29,994 = 49.5% of 2nd PP and 14.8% of the / total Solenoid contract) progress payment on the Solenoid / contract.
- 14211002X: Steps: Answer all pre bid questions (done); Initial Evaluation (done); Review of response/discussions1 (done); Eval Final Round (done); Release best and final (done); Evaluate Best and Final (done); Award Contract (done)
- 14212002X: Steps: Answer all pre bid questions (done); Evaluate proposal (done); Review of responses/discussions (done); Eval Final Round (done); Release best and final (done); Eval Best and Final (done); Award Contract (done)

| ID | WBS | Activity | Type | Duration | Start | Finish | Predecessors | Complete | Planned start | Planned finish | Resources | Cost | Actual cost | Planned FinishUDF | Calculated Remaining Total Cost | MONTHLY EV COST | RESP - Responsibility | STRT%COMP for CM EVM | FNSH%COMP for CM EVM | CR 07-002 | EVMS Reporting Codes | CAM RESPONSIBLE | CR 07-027 | Milestone Level | Remaining Material Cost Based on % Compl | Claimed Material Cost Based on % Complet | Initial Claimed Material Calc | Claimed Material Divider | ACT BRIDGING FY SPLIT | CR 08-016 | WBS ASSIGNMENT | EXPNS ACT BRIDGING FY SPLIT | CR 09-001 | CR 09-012 | LOE Divider | LOE Multiplier | CR 07-024 | CR 08-058 | CR 11-026 | CR 11-035 | ReBaseline Actuals Adjustment |
| --- | --- | --- | --- | --- | --- | --- | --- | --- | --- | --- | --- | --- | --- | --- | --- | --- | --- | --- | --- | --- | --- | --- | --- | --- | --- | --- | --- | --- | --- | --- | --- | --- | --- | --- | --- | --- | --- | --- | --- | --- | --- |
|  | 1 | **1.2.2.2.1.1 TOROIDAL MAGNET** |  |  |  |  |  |  |  |  |  |  |  |  |  |  |  |  |  |  |  |  |  |  |  |  |  |  |  |  |  |  |  |  |  |  |  |  |  |  |  |
|  | 2 | **1.2.2.2.1.2 SOLENOID** |  |  |  |  |  |  |  |  |  |  |  |  |  |  |  |  |  |  |  |  |  |  |  |  |  |  |  |  |  |  |  |  |  |  |  |  |  |  |  |
|  | 2 | **1.2.2.2.2 DETECTORS** |  |  | 2006-11-01 | 2013-08-30 |  |  |  |  |  |  |  |  |  |  |  |  |  |  |  |  |  |  |  |  |  |  |  |  |  |  |  |  |  |  |  |  |  |  |  |
| 1222211005 |  | SVT-Design overall layout (SILICON DTCTR) |  | 152d | 2006-11-01 A | 2007-06-15 A | 9-070M | 100% |  |  | MECH ENG [92 h]; MECH DES [337.54 h] | 20,582.05 | 20,582.05 | 2007-03-16 | 0 | 20609.49435 | ELOUADRHIRI L | 1 | 1 | 07-002 | N/A | LATIFA E |  |  |  |  |  |  |  |  |  |  |  |  |  |  |  |  |  |  |  |
| 1222213005 |  | DC- Design of the chamber & Stringing Fixture : Phase 1 (F DRFT CHAMB) |  | 108d | 2006-11-01 A | 2007-04-13 A | 9-070M | 100% |  |  | MECH TECH [245.48 h]; MECH DES [245.48 h]; CONTRB UNIV LBR [214.79 h]; MECH ENG [92 h] | 26,325.04 | 26,325.04 | 2007-03-30 | 0 | 26329.2428 | ELOUADRHIRI L | 1 | 1 | 07-002 | N/A | LATIFA E |  |  |  |  |  |  |  |  |  |  |  |  |  |  |  |  |  |  |  |
| 1222213010 |  | DC-Design On-chamber Electronics: Phase 1 (F DRFT CHAMB) |  | 87d | 2006-11-01 A | 2007-03-15 A | 9-070M | 100% |  |  | ELEC TECH [122.74 h]; OFFICE [214.79 h]; ELEC ENG [122.74 h]; ELEC DES [337.54 h] | 33,913.06 | 33,913.06 | 2007-03-30 | 0 | 33913.062 | ELOUADRHIRI L | 1 | 1 | 07-002 | N/A | LATIFA E |  |  |  |  |  |  |  |  |  |  |  |  |  |  |  |  |  |  |  |
| 1222223005 |  | Designing the mounting (FCAL) |  | 225d | 2006-11-01 A | 2007-09-28 A | 9-070M | 100% |  |  | MECH DES [123 h]; MECH ENG [97.47 h] | 11,300.37 | 11,300.37 | 2007-03-02 | 0 | 11472.3372 | ELOUADRHIRI L | 1 | 1 | 07-002 | N/A | LATIFA E | 07-027 |  |  |  |  |  |  |  |  |  |  |  |  |  |  |  |  |  |  |
| 1222223010 |  | Design Box with end plates (FCAL) |  | 225d | 2006-11-01 A | 2007-09-28 A | 9-070M | 100% |  |  | MECH DES [184.11 h]; MECH ENG [66.78 h] | 12,063.07 | 12,063.07 | 2007-03-02 | 0 | 12286.2379 | ELOUADRHIRI L | 1 | 1 | 07-002 | N/A | LATIFA E | 07-027 |  |  |  |  |  |  |  |  |  |  |  |  |  |  |  |  |  |  |
| 1222231005 |  | Design of Light Guides (CTOF) |  | 225d | 2006-11-01 A | 2007-09-28 A | 9-070M | 100% |  |  | MECH DES [158.8 h]; SCIENTIST [122.74 h]; MECH ENG [90.25 h] | 20,130.67 | 20,130.67 | 2007-03-30 | 0 | 20492.1246 | ELOUADRHIRI L | 1 | 1 | 07-002 | N/A | LATIFA E | 07-027 |  |  |  |  |  |  |  |  |  |  |  |  |  |  |  |  |  |  |
| 1222232010 |  | Design of the light guides (FTOF) |  | 225d | 2006-11-01 A | 2007-09-28 A | 9-070M | 100% |  |  | MECH ENG [61.37 h]; MECH DES [122.74 h]; SCIENTIST [122.74 h] | 16,799.05 | 16,799.05 | 2007-04-06 | 0 | 17104.506344 | ELOUADRHIRI L | 1 | 1 | 07-002 | N/A | LATIFA E | 07-027 |  |  |  |  |  |  |  |  |  |  |  |  |  |  |  |  |  |  |
| 1222232015 |  | Magnetic shielding design (FTOF) |  | 225d | 2006-11-01 A | 2007-09-28 A | 9-070M FS+58d | 100% |  |  | MECH DES [122.74 h]; SCIENTIST [122.74 h]; MECH ENG [61.37 h] | 16,799.05 | 16,799.05 | 2007-06-28 | 0 | 17041.290334 | ELOUADRHIRI L | 1 | 1 | 07-002 | N/A | LATIFA E | 07-027 |  |  |  |  |  |  |  |  |  |  |  |  |  |  |  |  |  |  |
| 1222241005 |  | Design of the mirror 6 sectors (HTCC) |  | 193d | 2006-11-01 A | 2007-08-14 A | 9-070M FS+60d | 100% |  |  | MECH ENG [92 h]; SCIENTIST [184.11 h] | 17,328.05 | 17,328.05 | 2007-06-25 | 0 | 17452.98515 | ELOUADRHIRI L | 1 | 1 | 07-002 | N/A | LATIFA E | 07-027 |  |  |  |  |  |  |  |  |  |  |  |  |  |  |  |  |  |  |
| 1222241010 |  | Design of the Module (HTCC) |  | 193d | 2006-11-01 A | 2007-08-14 A | 9-070M FS+73d | 100% |  |  | MECH DES [521.64 h]; ELEC DES [30.8 h]; SCIENTIST [61.37 h]; MECH ENG [30.8 h] | 29,916.74 | 29,916.74 | 2007-06-14 | 0 | 30169.000795 | ELOUADRHIRI L | 1 | 1 | 07-002 | N/A | LATIFA E | 07-027 |  |  |  |  |  |  |  |  |  |  |  |  |  |  |  |  |  |  |
| 1222241015 |  | Design of the Mounting Frames (HTCC) |  | 225d | 2006-11-01 A | 2007-09-28 A | 1222241010 | 100% |  |  | SCIENTIST [61.37 h]; MECH DES [337.54 h] | 18,468.68 | 18,468.68 | 2007-09-28 | 0 | 17757.563091 | ELOUADRHIRI L | 1 | 1 | 07-002 | N/A | LATIFA E | 07-027 |  |  |  |  |  |  |  |  |  |  |  |  |  |  |  |  |  |  |
| 1222242005 |  | Design modification to the mirrors (LTCC) |  | 279d | 2006-11-01 A | 2007-12-17 A | 9-070M FS+60d | 100% |  |  | VISTNG USERS [306.85 h] | 5,222.83 | 5,222.83 | 2007-06-11 | 0 | 5280.8885 | ELOUADRHIRI L | 1 | 1 | 07-002 | N/A | LATIFA E | 07-027 |  |  |  |  |  |  |  |  |  |  |  |  |  |  |  |  |  |  |
| 1222211010 |  | SVT-Design support structure (SILICON DTCTR) |  | 205d | 2006-12-01 A | 2007-09-28 A | 1222211005 | 100% |  |  | MECH ENG [153.43 h]; MECH DES [337.54 h] | 23,974.68 | 23,974.68 | 2007-09-28 | 0 | 23600.69268 | ELOUADRHIRI L | 1 | 1 | 07-002 | N/A | LATIFA E |  |  |  |  |  |  |  |  |  |  |  |  |  |  |  |  |  |  |  |
| 1222211015 |  | SVT- Design of the VME Board (SILICON DTCTR) |  | 205d | 2006-12-01 A | 2007-09-28 A | 9-070M | 100% |  |  | ELEC DES [577.6 h]; ELEC ENG [153.43 h] | 35,336.68 | 35,336.68 | 2007-04-06 | 0 | 36092.9966 | ELOUADRHIRI L | 1 | 1 | 07-002 | N/A | LATIFA E |  |  |  |  |  |  |  |  |  |  |  |  |  |  |  |  |  |  |  |
| 1222231010 |  | Design of tools for the LG bending technique (CTOF) |  | 205d | 2006-12-01 A | 2007-09-28 A | 9-070M FS+58d | 100% |  |  | SCIENTIST [122.74 h]; MECH ENG [90.25 h]; MECH DES [158.84 h] | 20,097.14 | 20,097.14 | 2007-06-21 | 0 | 20421.487216 | ELOUADRHIRI L | 1 | 1 | 07-002 | N/A | LATIFA E | 07-027 |  |  |  |  |  |  |  |  |  |  |  |  |  |  |  |  |  |  |
| 1222232005 |  | Design of the backing structure for scintillators (FTOF) |  | 205d | 2006-12-01 A | 2007-09-28 A | 9-070M | 100% |  |  | MECH DES [122.74 h]; SCIENTIST [122.74 h]; MECH ENG [61.37 h] | 16,768.73 | 16,768.73 | 2007-04-06 | 0 | 17104.506344 | ELOUADRHIRI L | 1 | 1 | 07-002 | N/A | LATIFA E | 07-027 |  |  |  |  |  |  |  |  |  |  |  |  |  |  |  |  |  |  |
| 1222211020 |  | SVT- Design readout software (SILICON DTCTR) |  | 189d | 2007-01-02 A | 2007-09-28 A | 1222211015 | 100% |  |  | ELEC ENG [184.11 h] | 11,564.75 | 11,564.75 | 2007-09-28 | 0 | 11265.382138 | ELOUADRHIRI L | 1 | 1 | 07-002 | N/A | LATIFA E |  |  |  |  |  |  |  |  |  |  |  |  |  |  |  |  |  |  |  |
| 1222223015 |  | Design scintillator holders (FCAL) |  | 189d | 2007-01-02 A | 2007-09-28 A | 1222223005 FS-43d, 1222223010 FS-43d | 100% |  |  | MECH DES [122.74 h]; MECH ENG [66.78 h] | 9,377.12 | 9,377.12 | 2007-05-25 | 0 | 9565.7058 | ELOUADRHIRI L | 1 | 1 | 07-002 | N/A | LATIFA E | 07-027 |  |  |  |  |  |  |  |  |  |  |  |  |  |  |  |  |  |  |
| 1222223020 |  | Design lead sheets (FCAL) |  | 189d | 2007-01-02 A | 2007-09-28 A | 1222223015 FS-19d | 100% |  |  | MECH ENG [46.8 h]; MECH DES [18.05 h] | 3,643.74 | 3,643.74 | 2007-06-25 | 0 | 3692.23 | ELOUADRHIRI L | 1 | 1 | 07-002 | N/A | LATIFA E | 07-027 |  |  |  |  |  |  |  |  |  |  |  |  |  |  |  |  |  |  |
| 1222223025 |  | Design pmt holders fiber routing and light guides (FCAL) |  | 189d | 2007-01-02 A | 2007-09-28 A | 9-070M | 100% |  |  | MECH DES [184.11 h] | 7,930.32 | 7,930.32 | 2007-03-02 | 0 | 8161.5963 | ELOUADRHIRI L | 1 | 1 | 07-002 | N/A | LATIFA E | 07-027 |  |  |  |  |  |  |  |  |  |  |  |  |  |  |  |  |  |  |
| 1222223030 |  | Design lifting plan and hardware (FCAL) |  | 189d | 2007-01-02 A | 2007-09-28 A | 1222223015 FS-85d | 100% |  |  | MECH DES [61.37 h]; MECH ENG [66.78 h] | 6,733.68 | 6,733.68 | 2007-07-24 | 0 | 6845.1737 | ELOUADRHIRI L | 1 | 1 | 07-002 | N/A | LATIFA E | 07-027 |  |  |  |  |  |  |  |  |  |  |  |  |  |  |  |  |  |  |
| 1222213020 |  | DC-Design On-chamber Electronics: Phase 2 (F DRFT CHAMB) |  | 138d | 2007-03-16 A | 2007-09-28 A | 1222213010 | 100% |  |  | ELEC ENG [122.74 h]; ELEC DES [337.6 h]; ELEC TECH [122.74 h]; CONTRB UNIV LBR [245.48 h] | 27,222.94 | 27,222.94 | 2007-09-28 | 0 | 27122.845007 | ELOUADRHIRI L | 1 | 1 | 07-002 | N/A | LATIFA E |  |  |  |  |  |  |  |  |  |  |  |  |  |  |  |  |  |  |  |
| 1222213015 |  | DC- Design of the chamber & Stringing Fixture : Phase 2 (F DRFT CHAMB) |  | 118d | 2007-04-13 A | 2007-09-28 A | 1222213005 | 100% |  |  | MECH DES [245.48 h]; MECH TECH [245.48 h]; MECH ENG [92 h] | 25,569.04 | 25,569.04 | 2007-09-28 | 0 | 25619.696948 | ELOUADRHIRI L | 1 | 1 | 07-002 | N/A | LATIFA E |  |  |  |  |  |  |  |  |  |  |  |  |  |  |  |  |  |  |  |
| 1222232020 |  | PMT housing and grounding design (FTOF) |  | 106d | 2007-05-01 A | 2007-09-28 A | 9-070M FS+89d | 100% |  |  | MECH ENG [61.2 h]; MECH DES [122.74 h]; SCIENTIST [122.74 h] | 16,466.67 | 16,466.67 | 2007-09-28 | 0 | 16656.81429 | ELOUADRHIRI L | 1 | 1 | 07-002 | N/A | LATIFA E | 07-027 |  |  |  |  |  |  |  |  |  |  |  |  |  |  |  |  |  |  |
| 1222242010 |  | Design of the support structure (LTCC) |  | 160d | 2007-05-01 A | 2007-12-17 A | 1222242005 FS-58d | 100% |  |  | MECH ENG [31.6 h]; MECH DES [306.85 h] | 14,911.99 | 14,911.99 | 2007-09-28 | 0 | 15097.468504 | ELOUADRHIRI L | 1 | 1 | 07-002 | N/A | LATIFA E | 07-027 |  |  |  |  |  |  |  |  |  |  |  |  |  |  |  |  |  |  |
| 1222231015 |  | Design the support for the triplet with 1 m long bend LG's (CTOF) |  | 74d | 2007-06-15 A | 2007-09-28 A | 9-070M FS+89d | 100% |  |  | MECH ENG [61.37 h]; MECH DES [194.94 h]; SCIENTIST [122.74 h] | 19,262.22 | 19,262.22 | 2007-09-28 | 0 | 20197.287307 | ELOUADRHIRI L | 1 | 1 | 07-002 | N/A | LATIFA E | 07-027 |  |  |  |  |  |  |  |  |  |  |  |  |  |  |  |  |  |  |
| 1222213025M |  | FDC- FY07 Techncl Dsgn Report & Sfty Assessmnt (DETCTR) | milestone | 0d | 2007-09-28 A | 2007-09-28 A | 1222213020, 1222213015 | 100% | 2007-10-25 | 2007-10-25 |  |  |  | 2007-09-28 |  | 0 | ELOUADRHIRI L | 1 | 1 | 07-002 | N/A | LATIFA E |  | 6 |  |  |  |  |  |  |  |  |  |  |  |  |  |  |  |  |  |
| 1222223030M |  | EC-FY07 technical design report and safety assessment (FCAL) | milestone | 0d | 2007-09-28 A | 2007-09-28 A | 1222223025, 1222223030, 1222223020 | 100% | 2007-10-25 | 2007-10-25 |  |  |  | 2007-07-24 |  | 0 | ELOUADRHIRI L | 1 | 1 | 07-002 | N/A | LATIFA E |  | 5 |  |  |  |  |  |  |  |  |  |  |  |  |  |  |  |  |  |
| 1222231020M |  | CTOF-FY07 Techncl Dsgn Report & Sfty Assessmnt (DETCTR) | milestone | 0d | 2007-09-28 A | 2007-09-28 A | 1222231015, 1222231010, 1222231005 | 100% | 2007-10-25 | 2007-10-25 |  |  |  | 2007-09-28 |  | 0 | ELOUADRHIRI L | 1 | 1 | 07-002 | N/A | LATIFA E |  | 6 |  |  |  |  |  |  |  |  |  |  |  |  |  |  |  |  |  |
| 1222232020M |  | FTOF- FY07 technical design report and safety assessment | milestone | 0d | 2007-09-28 A | 2007-09-28 A | 1222232020, 1222232010, 1222232005, 1222232015 | 100% | 2007-10-25 | 2007-10-25 |  |  |  | 2007-09-28 |  | 0 | ELOUADRHIRI L | 1 | 1 | 07-002 | N/A | LATIFA E |  | 5 |  |  |  |  |  |  |  |  |  |  |  |  |  |  |  |  |  |
| 1222241025M |  | FY07 technical design report and safety assessment (HTCC) | milestone | 0d | 2007-09-28 A | 2007-09-28 A | 1222241005, 1222241015 | 100% | 2007-10-25 | 2007-10-25 |  |  |  | 2007-09-28 |  | 0 | ELOUADRHIRI L | 1 | 1 | 07-002 | N/A | LATIFA E | 07-027 | 5 |  |  |  |  |  |  |  |  |  |  |  |  |  |  |  |  |  |
| 12222005 |  | SVT- Dsgn Supprt Struct Optimztn Comptd (DETCTR) |  | 366d | 2007-10-01 A | 2009-03-27 A | 1222211020, 9-080M, 1222211010 | 100% |  |  | PROCUREMENT<$50K 60; MECH DES [440 h] | 21,659.94 | 18,884.13 |  | 0 | 21467.01 | ELOUADRHIRI L | 1 | 1 |  | N/A | LATIFA E | 07-027 |  | 0 | 2775.81 | 277581 | 100 |  |  |  |  |  |  |  |  |  |  |  |  |  |
| 12222025 |  | FDC- Comp Dsgn of Chamb & Stringing Fixture (DETCTR) |  | 246d | 2007-10-01 A | 2008-09-26 A | 12222020M | 100% |  |  | MECH DES [640 h]; MECH TECH [640 h]; CONTRB UNIV LBR [1920 h]; MECH ENG [240 h]; SCIENTIST [40 h] | 69,607.6 | 69,607.6 |  | 0 | 69607.6 | ELOUADRHIRI L | 1 | 1 |  | N/A | LATIFA E |  |  |  |  |  |  |  |  |  |  |  |  |  |  |  |  |  |  |  |
| 12222030 |  | FDC- Comp Dsgn of Chambers Electrnc's (DETCTR) |  | 382d | 2007-10-01 A | 2009-04-20 A | 12222020M | 100% |  |  | ELEC DES [1200 h]; ELEC ENG [400 h]; ELEC TECH [600 h]; SCIENTIST [80 h]; CONTRB UNIV LBR [1920 h] | 107,893.61 | 107,893.61 |  | 0 | 106695.6 | ELOUADRHIRI L | 1 | 1 |  | N/A | LATIFA E |  |  |  |  |  |  |  |  |  |  |  |  |  |  |  |  |  |  |  |
| 12222045 |  | CTOF- Compltn of Light Guides Dsgn (DETCTR) |  | 319d | 2007-10-01 A | 2009-01-20 A | 1222231020M | 100% |  |  | MECH DES [40 h]; SCIENTIST [40 h]; MECH ENG [120 h]; ELEC DES [200 h] | 20,666.91 | 20,666.91 |  | 0 | 20198.9415 | ELOUADRHIRI L | 1 | 1 |  | N/A | LATIFA E | 07-027 |  |  |  |  |  |  |  |  |  |  |  |  |  |  |  |  |  |  |
| 12222050 |  | CTOF- Compltn of Dsgn LG bending (DETCTR) |  | 227d | 2007-10-01 A | 2008-08-29 A | 1222231020M | 100% |  |  | MECH DES [40 h]; SCIENTIST [40 h]; MECH ENG [120 h] | 11,610.8 | 11,610.8 |  | 0 | 11428.8065 | ELOUADRHIRI L | 1 | 1 |  | N/A | LATIFA E | 07-027 |  |  |  |  |  |  |  |  |  |  |  |  |  |  |  |  |  |  |
| 12222055 |  | PROC CTOF- Comp Dsgn Supprt for Triplet with 1 m long bend LG's (DETCTR)+ |  | 341d | 2007-10-01 A | 2009-02-20 A | 12222050, 1132890M | 100% |  |  | PROCUREMENT<$50K 60 NO ESCALATION FY09 | 2,765.49 |  |  | 0 | 2765.492 | ELOUADRHIRI L | 1 | 1 |  | N/A | LATIFA E | 07-027 |  | 0 | 2765.49 | 276549 | 100 | FY08-09 | 08-016 | 1.2.2.2.2 | EXP0809 | 09-001 | 09-012 |  |  |  |  |  |  |  |
| 12222055a |  | FY08 LAB/EXP CTOF- Comp Dsgn Supprt for Triplet with 1 m long bend LG's (DETCTR)+ |  | 2d | 2007-10-01 A | 2007-10-02 A | 1132890M, 12222050 | 100% |  |  | SCIENTIST [0.33 h]; MECH ENG [1 h]; MECH DES [1 h] | 124.87 | 124.87 |  | 0 | 124.8691 | ELOUADRHIRI L | 1 | 1 |  | N/A | LATIFA E | 07-027 |  |  |  |  |  | FY08-09 | 08-016 | 1.2.2.2.2 | EXP0809 | 09-001 | 09-012 |  |  |  |  |  |  |  |
| 12222060 |  | FTOF- Comp Dsgn of Backing Struct for Scintillators (DETCTR) + |  | 266d | 2007-10-01 A | 2008-10-24 A | 1222232005, 1222232020M | 100% |  |  | MECH ENG [120 h]; SCIENTIST [40 h]; MECH DES [40 h] | 11,635.87 | 11,635.87 |  | 0 | 11610.8 | ELOUADRHIRI L | 1 | 1 |  | N/A | LATIFA E | 07-027 |  |  |  |  |  |  |  |  |  |  |  |  |  |  |  |  |  |  |
| 12222065 |  | FTOF- Comp Magnetic Shielding Dsgn (DETCTR) + |  | 227d | 2007-10-01 A | 2008-08-29 A | 1222232020M, 1222232015 | 100% |  |  | MECH ENG [120 h]; MECH DES [80 h]; SCIENTIST [40 h] | 13,310 | 13,310 |  | 0 | 13310 | ELOUADRHIRI L | 1 | 1 |  | N/A | LATIFA E | 07-027 |  |  |  |  |  |  |  |  |  |  |  |  |  |  |  |  |  |  |
| 12222070 |  | FTOF- Comp PMT Housing & Grounding Dsgn (DETCTR)+ |  | 266d | 2007-10-01 A | 2008-10-24 A | 1222232020M, 1222232020 | 100% |  |  | MECH ENG [120 h]; MECH DES [40 h]; SCIENTIST [40 h]; ELEC DES [200 h] | 20,565.22 | 20,565.22 |  | 0 | 20520.8 | ELOUADRHIRI L | 1 | 1 |  | N/A | LATIFA E | 07-027 |  |  |  |  |  |  |  |  |  |  |  |  |  |  |  |  |  |  |
| 12222075 |  | PROC HTCC- Dsgn of Whole Module (DETCTR) |  | 319d | 2007-10-01 A | 2009-01-20 A | 1222241025M, 1132831M | 100% |  |  | PROCUREMENT<$50K 60 NO ESCALATION FY09 | 2,765.49 |  |  | 0 | 2765.492 | ELOUADRHIRI L | 1 | 1 |  | N/A | LATIFA E |  |  | 0 | 2765.49 | 276549 | 100 | FY08-09 | 08-016 | 1.2.2.2.2 | EXP0809 | 09-001 | 09-012 |  |  |  |  |  |  |  |
| 12222075a |  | FY08 LAB/EXP HTCC- Dsgn of Whole Module (DETCTR) |  | 2d | 2007-10-01 A | 2007-10-02 A | 1132831M, 1222241025M | 100% |  |  | MECH DES [2.2 h]; ELEC DES [2.2 h]; SCIENTIST [0.4 h]; MECH ENG [0.8 h] | 265.85 | 265.85 |  | 0 | 265.846 | ELOUADRHIRI L | 1 | 1 |  | N/A | LATIFA E |  |  |  |  |  |  | FY08-09 | 08-016 | 1.2.2.2.2 | EXP0809 | 09-001 | 09-012 |  |  |  |  |  |  |  |
| 1222232030 |  | FTOF- Comp Dsgn of Light Guides (DETCTR) (FY-08) |  | 227d | 2007-10-01 A | 2008-08-29 A | 1222232010 | 100% |  |  | SCIENTIST [40 h]; MECH ENG [120 h]; MECH DES [40 h] | 11,610.8 | 11,610.8 |  | 0 | 11489.00144 | ELOUADRHIRI L | 1 | 1 |  | N/A | LATIFA E | 07-027 |  |  |  |  |  |  |  |  |  |  |  |  |  |  |  |  |  |  |
| 12222055b |  | FY09 LAB/EXP CTOF- Comp Dsgn Supprt for Triplet with 1 m long bend LG's (DETCTR)+ |  | 380d | 2007-10-03 A | 2009-04-20 A | 12222055a | 100% |  |  | MECH ENG [119 h]; MECH DES [119 h]; SCIENTIST [39.67 h] | 15,051.91 | 15,051.91 |  | 0 | 15359.5442 | ELOUADRHIRI L | 1 | 1 |  | N/A | LATIFA E | 07-027 |  |  |  |  |  | FY08-09 | 08-016 | 1.2.2.2.2 | EXP0809 | 09-001 | 09-012 |  |  |  |  |  |  |  |
| 12222075b |  | FY09 LAB/EXP HTCC- Dsgn of Whole Module (DETCTR) |  | 339d | 2007-10-03 A | 2009-02-20 A | 12222075a | 100% |  |  | SCIENTIST [79.6 h]; MECH DES [437.8 h]; MECH ENG [159.2 h]; ELEC DES [437.8 h] | 53,367.95 | 53,367.95 |  | 0 | 54596.844 | ELOUADRHIRI L | 1 | 1 |  | N/A | LATIFA E |  |  |  |  |  |  | FY08-09 | 08-016 | 1.2.2.2.2 | EXP0809 | 09-001 | 09-012 |  |  |  |  |  |  |  |
| 12222000 |  | FY08 SVT- Comp Dsgn Layout (DETCTR)+ |  | 226d | 2007-10-16 A | 2008-09-16 A | 1132897 | 100% | 2007-10-16 | 2008-09-15 | MECH DES [392 h] | 16,652.16 | 16,652.16 |  | 0 | 16652.16 | ELOUADRHIRI L | 1 | 1 |  | N/A | LATIFA E | 07-027 |  |  |  |  |  | FY08-09 |  | 1.2.2.2.2 | EXP0809 | 09-001 |  |  |  |  |  |  |  |  |
| 12222020M |  | FDC- Resource Loaded Schedule for Fab (DETCTR) | milestone | 0d | 2007-10-22 A | 2007-10-22 A | 1222213025M | 100% | 2007-11-01 | 2007-11-01 |  |  |  |  |  | 0 | ELOUADRHIRI L | 1 | 1 |  | N/A | LATIFA E |  | 6 |  |  |  |  |  |  |  |  |  |  |  |  |  |  |  |  |  |
| 12222010 |  | SVT- Dsgn of VME Board Comptd (DETCTR) |  | 204d | 2007-11-01 A | 2008-08-29 A | 12222005 FS-31d | 100% |  |  | ELEC DES [880 h]; ELEC ENG [880 h] | 93,975.2 | 93,975.2 |  | 0 | 93975.2 | ELOUADRHIRI L | 1 | 1 |  | N/A | LATIFA E | 07-027 |  |  |  |  |  |  |  |  |  |  |  |  |  |  |  |  |  |  |
| 12222015 |  | FY08 SVT- Dsgn Readout Software Comptd (DETCTR) |  | 235.21d | 2007-11-01 A | 2008-10-15 A | 12222005 FS-31d | 100% |  |  | COMP SCIENT [190.47 h]; ELEC ENG [761.88 h]; OFFICE [17.32 h]; CONTRB UNIV LBR [761.88 h]; ELEC TECH [380.94 h]; SCIENTIST [10.39 h] | 74,458.04 | 74,458.04 |  | 0 | 74355.0072 | ELOUADRHIRI L | 1 | 1 |  | N/A | LATIFA E |  |  |  |  |  |  |  |  | 1.2.2.2.2 | EXP0809 | 09-001 |  |  |  |  |  |  |  |  |
| 12222040 |  | FY08 EC- Comp Dsgn of Assy (DETCTR) |  | 1.02d | 2007-11-01 A | 2007-11-02 A | 1222223030M, 1132851M | 100% |  |  | SCIENTIST [0.27 h]; MECH ENG [0.93 h]; MECH DES [2.4 h] | 176.27 | 176.27 |  | 0 | 176.2761 | ELOUADRHIRI L | 1 | 1 |  | N/A | LATIFA E |  |  |  |  |  |  | FY08-09 |  | 1.2.2.2.2 | EXP0809 | 09-001 |  |  |  |  |  |  |  |  |
| 12222080 |  | LTCC- Dsgn Extended Working Volume (DETCTR) |  | 427d | 2007-11-01 A | 2009-07-27 A | 1222242015M | 100% |  |  | MECH ENG [120 h]; MECH DES [100 h]; SCIENTIST [32 h] | 13,867.73 | 13,867.73 |  | 0 | 13565.603818 | ELOUADRHIRI L | 1 | 1 |  | N/A | LATIFA E | 07-027 |  |  |  |  |  |  |  |  |  |  |  |  |  |  |  |  |  |  |
| 12222040a |  | FY09 EC- Comp Dsgn of Assy (DETCTR) |  | 294d | 2007-11-05 A | 2009-01-20 A | 12222040 | 100% |  |  | MECH ENG [139.07 h]; MECH DES [357.6 h]; SCIENTIST [39.73 h] | 26,467.63 | 26,467.63 |  | 0 | 27104.2905 | ELOUADRHIRI L | 1 | 1 |  | N/A | LATIFA E |  |  |  |  |  |  | FY08-09 |  | 1.2.2.2.2 | EXP0809 | 09-001 |  |  |  |  |  |  |  |  |
| 1222242015M |  | LTCC- FY07 Techncl Dsgn Report & Sfty Assessmnt (DETCTR) | milestone | 0d | 2007-12-17 A | 2007-12-17 A | 1222242010 | 100% | 2008-01-23 | 2008-01-23 |  |  |  | 2007-09-28 |  | 0 | ELOUADRHIRI L | 1 | 1 | 07-002 | N/A | LATIFA E |  | 6 |  |  |  |  |  |  |  |  |  |  |  |  |  |  |  |  |  |
| 12222000a |  | FY09 SVT- Comp Dsgn Layout (DETCTR)+ |  | 128d | 2008-09-17 A | 2009-03-27 A | 12222000 | 100% |  |  | MECH DES [48 h] | 2,099.22 | 2,099.22 |  | 0 | 2104.32 | ELOUADRHIRI L | 1 | 1 |  | N/A | LATIFA E | 07-027 |  |  |  |  |  | FY08-09 |  | 1.2.2.2.2 | EXP0809 | 09-001 |  |  |  |  |  |  |  |  |
| 12222015a |  | FY09 SVT- Dsgn Readout Software Comptd (DETCTR) |  | 158d | 2008-10-01 A | 2009-05-25 A | 12222015 | 100% | 2008-10-01 | 2009-05-22 | SCIENTIST [1.61 h]; CONTRB UNIV LBR [118.12 h]; ELEC TECH [59.06 h]; OFFICE [2.68 h]; COMP SCIENT [29.53 h]; ELEC ENG [118.12 h] | 11,895.62 | 11,895.62 |  | 0 | 11895.6091 | ELOUADRHIRI L | 1 | 1 |  | N/A | LATIFA E |  |  |  |  |  |  |  |  | 1.2.2.2.2 | EXP0809 | 09-001 |  |  |  |  |  |  |  |  |
| 142213009EX |  | FY09 Travel (FWD Chambers) |  | 15d | 2008-12-02 A | 2008-12-22 A | 9-090M | 100% |  |  | TRAVEL | 633.31 |  |  | 0 | 633.307987 | ELOUADRHIRI L | 1 | 1 |  | E | LATIFA E |  |  |  |  |  |  |  |  |  |  |  |  | 100 | 100 | 07-024 | 08-058 | 11-026 | 11 -035 |  |
| 1222223040 |  | EC- Dsgn of Lifting & Mounting Hardware (DETCTR)+ |  | 110d | 2008-12-10 A | 2009-05-25 A | 12222040a FS-71d | 100% | 2008-12-10 | 2009-05-22 | MECH DES [320 h]; SCIENTIST [52 h]; MECH ENG [200 h] | 30,132.32 | 30,132.32 |  | 0 | 30132.32 | ELOUADRHIRI L | 1 | 1 |  | H | LATIFA E | 07-027 |  |  |  |  |  |  |  |  |  |  |  |  |  |  |  |  |  |  |
| 1222223041M |  | EC- Final Techncl Dsgn Report & Sfty Assessmnt (DETCTR)+ | milestone | 0d | 2009-03-27 A | 2009-03-27 A | 12222040a FS+47d | 100% | 2009-04-01 | 2009-04-01 |  |  |  |  |  | 0 | ELOUADRHIRI L | 1 | 1 |  | M | LATIFA E |  | 6 |  |  |  |  |  |  |  |  |  |  |  |  |  |  |  |  |  |
| 1222241035M |  | HTCC- Techncl Dsgn Report (DETCTR)+ | milestone | 0d | 2009-04-01 A | 2009-04-01 A | 12222075b FS+50d, 12222075 | 100% | 2009-05-01 | 2009-05-01 |  |  |  |  |  | 0 | ELOUADRHIRI L | 1 | 1 |  | M | LATIFA E |  | 6 |  |  |  |  |  |  |  |  |  |  |  |  |  |  |  |  |  |
| 12222035M |  | FDC-Compltn of PED (DETCTR)+ | milestone | 0d | 2009-04-20 A | 2009-04-20 A | 12222025, 12222030, 1132865M | 100% | 2009-06-02 | 2009-06-02 |  |  |  |  |  | 0 | ELOUADRHIRI L | 1 | 1 |  | M | LATIFA E | 07-027 | 6 |  |  |  |  |  |  |  |  |  |  |  |  |  |  |  |  |  |
| 12222015M |  | SVT- Techncl Dsgn Report & drawings (DETCTR)+ | milestone | 0d | 2009-05-25 A | 2009-05-25 A | 12222015a, 12222010, 1132800M | 100% | 2009-06-26 | 2009-06-26 |  |  |  |  |  | 0 | ELOUADRHIRI L | 1 | 1 |  | M | LATIFA E | 07-027 | 6 |  |  |  |  |  |  |  |  |  |  |  |  |  |  |  |  |  |
| 1222242020 |  | Re-Baseline Actuals Adjustment |  | 1d | 2013-08-30 A | 2013-08-30 A |  | 100% | 2013-09-03 | 2013-09-03 | PROCUREMENT>$50K 69 NO ESCALATION | 504,259.51 |  |  |  | 504259.51 |  |  |  |  |  |  |  |  | 0 | 504259.51 | 50425951 | 100 |  |  |  |  |  |  |  |  |  |  |  |  | ADJ |

Notes:
- 1222232030: Corrective Actions: Latifa Plans To Start In April 2007. PMC

| ID | WBS | Activity | Type | Duration | Start | Finish | Predecessors | Complete | Planned start | Planned finish | Resources | Cost | Actual cost | Planned FinishUDF | Calculated Remaining Total Cost | MONTHLY EV COST | RESP - Responsibility | STRT%COMP for CM EVM | FNSH%COMP for CM EVM | CR 07-002 | EVMS Reporting Codes | CAM RESPONSIBLE | Remaining Material Cost Based on % Compl | Claimed Material Cost Based on % Complet | Initial Claimed Material Calc | Claimed Material Divider | CR 07-027 | Milestone Level | ReBaseline Actuals Adjustment |
| --- | --- | --- | --- | --- | --- | --- | --- | --- | --- | --- | --- | --- | --- | --- | --- | --- | --- | --- | --- | --- | --- | --- | --- | --- | --- | --- | --- | --- | --- |
|  | 1 | **1.2.2.2.2.1 TRACKING** |  |  |  |  |  |  |  |  |  |  |  |  |  |  |  |  |  |  |  |  |  |  |  |  |  |  |  |
|  | 1 | **1.2.2.2.2.1.1 SILICON DETECTOR** |  |  |  |  |  |  |  |  |  |  |  |  |  |  |  |  |  |  |  |  |  |  |  |  |  |  |  |
|  | 2 | **1.2.2.2.2.1.2 CENTRAL TRACKER** |  |  |  |  |  |  |  |  |  |  |  |  |  |  |  |  |  |  |  |  |  |  |  |  |  |  |  |
|  | 3 | **1.2.2.2.2.1.3 FORWARD DRIFT CHAMBERS** |  |  |  |  |  |  |  |  |  |  |  |  |  |  |  |  |  |  |  |  |  |  |  |  |  |  |  |
|  | 2 | **1.2.2.2.2.2 CALORIMETRY** |  |  |  |  |  |  |  |  |  |  |  |  |  |  |  |  |  |  |  |  |  |  |  |  |  |  |  |
|  | 1 | **1.2.2.2.2.2.1 CENTRAL CALORIMETER** |  |  |  |  |  |  |  |  |  |  |  |  |  |  |  |  |  |  |  |  |  |  |  |  |  |  |  |
|  | 2 | **1.2.2.2.2.2.2 COIL CALORIMETER** |  |  |  |  |  |  |  |  |  |  |  |  |  |  |  |  |  |  |  |  |  |  |  |  |  |  |  |
|  | 3 | **1.2.2.2.2.2.3 FORWARD CALORIMETER** |  |  |  |  |  |  |  |  |  |  |  |  |  |  |  |  |  |  |  |  |  |  |  |  |  |  |  |
|  | 3 | **1.2.2.2.2.3 TIME OF FLIGHT** |  |  |  |  |  |  |  |  |  |  |  |  |  |  |  |  |  |  |  |  |  |  |  |  |  |  |  |
|  | 1 | **1.2.2.2.2.3.1 CENTRAL TOF** |  |  |  |  |  |  |  |  |  |  |  |  |  |  |  |  |  |  |  |  |  |  |  |  |  |  |  |
|  | 2 | **1.2.2.2.2.3.2 FORWARD TOF** |  |  |  |  |  |  |  |  |  |  |  |  |  |  |  |  |  |  |  |  |  |  |  |  |  |  |  |
|  | 4 | **1.2.2.2.2.4 CERENKOV** |  |  |  |  |  |  |  |  |  |  |  |  |  |  |  |  |  |  |  |  |  |  |  |  |  |  |  |
|  | 1 | **1.2.2.2.2.4.1 HIGH THRESHOLD CC** |  |  |  |  |  |  |  |  |  |  |  |  |  |  |  |  |  |  |  |  |  |  |  |  |  |  |  |
|  | 2 | **1.2.2.2.2.4.2 LOW THRESHOLD CC** |  |  |  |  |  |  |  |  |  |  |  |  |  |  |  |  |  |  |  |  |  |  |  |  |  |  |  |
|  | 3 | **1.2.2.2.3 COMPUTING** |  |  | 2006-12-01 | 2013-08-30 |  |  |  |  |  |  |  |  |  |  |  |  |  |  |  |  |  |  |  |  |  |  |  |
| 122231005 |  | Trigger- Level 1 design (TRGR SYS) |  | 205d | 2006-12-01 A | 2007-09-28 A | 9-070M | 100% |  |  | SCIENTIST [337.8 h] | 21,215.67 | 21,215.67 | 2007-03-16 | 0 | 21683.382 | ELOUADRHIRI L | 1 | 1 | 07-002 | N/A | LATIFA E |  |  |  |  |  |  |  |
| 122231010 |  | Trigger- Level 2 design (TRGR SYS) |  | 226d | 2006-12-01 A | 2007-10-29 A | 9-070M FS+56d | 100% |  |  | SCIENTIST [675.07 h] | 42,364.46 | 42,364.46 | 2007-06-26 | 0 | 43118.611096 | ELOUADRHIRI L | 1 | 1 | 07-002 | N/A | LATIFA E |  |  |  |  |  |  |  |
| 122231015 |  | Trigger- Electronic design (TRGR SYS) |  | 139d | 2007-04-13 A | 2007-10-29 A | 122231005, 122231010 FS-11d | 100% |  |  | SCIENTIST [158.84 h]; ELEC ENG [337.54 h] | 30,529.97 | 30,529.97 | 2007-09-28 | 0 | 29994.62703 | ELOUADRHIRI L | 1 | 1 | 07-002 | N/A | LATIFA E |  |  |  |  |  |  |  |
| 12223025 |  | Trigger- Compltn of L-1 Dsgn Scheme (COMPUTNG) |  | 319d | 2007-10-01 A | 2009-01-20 A | 122231020M, 122231015 | 100% |  |  | ELEC ENG [40 h]; SCIENTIST [84 h]; PROCUREMENT<$50K 60 | 10,540.69 | 7,775.2 |  | 0 | 10485.772 | ELOUADRHIRI L | 1 | 1 |  | N/A | LATIFA E | 0 | 2765.49 | 276549 | 100 | 07-027 |  |  |
| 122231020M |  | Trigger- Design Report (TRGR SYS) | milestone | 0d | 2007-10-29 A | 2007-10-29 A | 122231015 | 100% | 2007-12-05 | 2007-12-05 |  |  |  | 2007-09-28 |  | 0 | ELOUADRHIRI L | 1 | 1 | 07-002 | N/A | LATIFA E |  |  |  |  |  | 5 |  |
| 12223030 |  | Trigger- Compltn of L-2 Dsgn Scheme (COMPUTNG) |  | 359d | 2007-11-01 A | 2009-04-20 A | 12223025 | 100% |  |  | SCIENTIST [60 h]; ELEC ENG [80 h] | 8,819.39 | 8,819.39 |  | 0 | 8715.4 | ELOUADRHIRI L | 1 | 1 |  | N/A | LATIFA E |  |  |  |  |  |  |  |
| 12223035 |  | Trigger- Compltn of Electronic Dsgn (COMPUTNG) |  | 398d | 2007-11-01 A | 2009-06-15 A | 12223030 | 100% |  |  | ELEC ENG [100 h] | 6,310.5 | 6,310.5 |  | 0 | 6224 | ELOUADRHIRI L | 1 | 1 |  | N/A | LATIFA E |  |  |  |  | 07-027 |  |  |
| 12223040M |  | CLAS12 Trigger Techncl Dsgn Report (COMPUTNG)+ | milestone | 0d | 2008-05-01 A | 2008-05-01 A | 12223035 | 100% | 2008-06-02 | 2008-06-02 |  |  |  |  |  | 0 | ELOUADRHIRI L | 1 | 1 |  | M | LATIFA E |  |  |  |  | 07-027 | 6 |  |
| 12223045 |  | CLAS12 Slow Control Dsgn Sys (COMPUTNG)++ |  | 84d | 2009-06-01 A | 2009-09-28 A | 9-090M FS+120d | 100% |  |  | PD UNIV STUDNT [440 h]; SCIENTIST [400 h] | 29,976.4 | 29,976.4 |  | 0 | 29976.4 | ELOUADRHIRI L | 1 | 1 |  | H | LATIFA E |  |  |  |  | 07-027 |  |  |
| 122231025 |  | Re-Baseline Actuals Adjustment |  | 1d | 2013-08-30 A | 2013-08-30 A |  | 100% | 2013-09-03 | 2013-09-03 | PROCUREMENT>$50K 69 NO ESCALATION | -68,118.29 |  |  |  |  |  |  |  |  |  |  |  |  |  | 100 |  |  | ADJ |

| ID | WBS | Activity | Type | Duration | Start | Finish | Predecessors | Complete | Planned start | Planned finish | Resources | Cost | Actual cost | Remaining Material Cost Based on % Compl | Claimed Material Cost Based on % Complet | Initial Claimed Material Calc | Claimed Material Divider | Calculated Remaining Total Cost | MONTHLY EV COST | RESP - Responsibility | STRT%COMP for CM EVM | FNSH%COMP for CM EVM | CR 07-027 | Profile change | EVMS Reporting Codes | CAM RESPONSIBLE | ReBaseline Actuals Adjustment | Planned FinishUDF | CR 07-002 | Milestone Level |
| --- | --- | --- | --- | --- | --- | --- | --- | --- | --- | --- | --- | --- | --- | --- | --- | --- | --- | --- | --- | --- | --- | --- | --- | --- | --- | --- | --- | --- | --- | --- |
|  | 1 | **1.2.2.2.3.1 TRIGGER SYSTEM (Scintillators)** |  |  |  |  |  |  |  |  |  |  |  |  |  |  |  |  |  |  |  |  |  |  |  |  |  |  |  |  |
|  | 2 | **1.2.2.2.3.2 DAQ** |  |  |  |  |  |  |  |  |  |  |  |  |  |  |  |  |  |  |  |  |  |  |  |  |  |  |  |  |
|  | 3 | **1.2.2.2.3.3 ONLINE COMPUTING** |  |  |  |  |  |  |  |  |  |  |  |  |  |  |  |  |  |  |  |  |  |  |  |  |  |  |  |  |
|  | 4 | **1.2.2.2.3.4 OFFLINE COMPUTING** |  |  |  |  |  |  |  |  |  |  |  |  |  |  |  |  |  |  |  |  |  |  |  |  |  |  |  |  |
|  | 5 | **1.2.2.2.3.5 SLOW CONTROLS** |  |  |  |  |  |  |  |  |  |  |  |  |  |  |  |  |  |  |  |  |  |  |  |  |  |  |  |  |
|  | 4 | **1.2.2.2.4 ELECTRONICS** |  |  | 2007-11-01 | 2013-08-30 |  |  |  |  |  |  |  |  |  |  |  |  |  |  |  |  |  |  |  |  |  |  |  |  |
| 12224005 |  | FADC Analysis (ADC) (ELECTRNC'S)++ |  | 359d | 2007-11-01 A | 2009-04-20 A | 9-080M FS+60d | 100% |  |  | PROCUREMENT<$50K 60; SCIENTIST [252 h] | 18,644.71 | 15,879.22 | 0 | 2765.49 | 276549 | 100 | 0 | 18457.532 | ELOUADRHIRI L | 1 | 1 | 07-027 | C | N/A | LATIFA E |  |  |  |  |
| 12224010 |  | Re-Baseline Actuals Adjustment |  | 1d | 2013-08-30 A | 2013-08-30 A |  | 100% | 2013-09-03 | 2013-09-03 | PROCUREMENT>$50K 69 NO ESCALATION | -18,458.17 |  |  |  |  | 100 |  |  |  |  |  |  |  |  |  | ADJ |  |  |  |
|  | 1 | **1.2.2.2.4.1 ADC** |  |  |  |  |  |  |  |  |  |  |  |  |  |  |  |  |  |  |  |  |  |  |  |  |  |  |  |  |
|  | 2 | **1.2.2.2.4.2 TDC** |  |  |  |  |  |  |  |  |  |  |  |  |  |  |  |  |  |  |  |  |  |  |  |  |  |  |  |  |
|  | 3 | **1.2.2.2.4.3 SCALERS** |  |  |  |  |  |  |  |  |  |  |  |  |  |  |  |  |  |  |  |  |  |  |  |  |  |  |  |  |
|  | 4 | **1.2.2.2.4.4 HIGH VOLTAGE** |  |  |  |  |  |  |  |  |  |  |  |  |  |  |  |  |  |  |  |  |  |  |  |  |  |  |  |  |
|  | 5 | **1.2.2.2.4.5 PRE-TRIGGER** |  |  |  |  |  |  |  |  |  |  |  |  |  |  |  |  |  |  |  |  |  |  |  |  |  |  |  |  |
|  | 6 | **1.2.2.2.4.6 LOGIC** |  |  |  |  |  |  |  |  |  |  |  |  |  |  |  |  |  |  |  |  |  |  |  |  |  |  |  |  |
|  | 7 | **1.2.2.2.4.7 CRATES, RACKS** |  |  |  |  |  |  |  |  |  |  |  |  |  |  |  |  |  |  |  |  |  |  |  |  |  |  |  |  |
|  | 5 | **1.2.2.2.5 BEAMLINE** |  |  | 2006-12-01 | 2013-08-30 |  |  |  |  |  |  |  |  |  |  |  |  |  |  |  |  |  |  |  |  |  |  |  |  |
| 122253000 |  | Target- Design of Longitudinal polarized target (TARGETS) |  | 205d | 2006-12-01 A | 2007-09-28 A | 9-070M FS+60d | 100% |  |  | MECH DES [521.64 h]; MECH ENG [456.67 h] | 50,507.14 | 50,507.14 |  |  |  |  | 0 | 50818.698132 | ELOUADRHIRI L | 1 | 1 |  |  | N/A | LATIFA E |  | 2007-08-07 | 07-002 |  |
| 122254005 |  | BL-Shielding design for central detector (BL COMPON) |  | 116d | 2007-01-02 A | 2007-06-15 A | 9-070M | 100% |  |  | VISTNG USERS [398.9 h] | 6,865.16 | 6,865.16 |  |  |  |  | 0 | 6865.15505 | ELOUADRHIRI L | 1 | 1 |  |  | N/A | LATIFA E |  | 2007-03-16 | 07-002 |  |
| 122254010 |  | BL-Forward detector shielding (BL COMPON) |  | 189d | 2007-01-02 A | 2007-09-28 A | 122254005 | 100% |  |  | MECH ENG [30.8 h]; VISTNG USERS [398.9 h]; MECH DES [122.74 h] | 13,946.33 | 13,946.33 |  |  |  |  | 0 | 13846.858936 | ELOUADRHIRI L | 1 | 1 |  |  | N/A | LATIFA E |  | 2007-09-28 | 07-002 |  |
| 122253005M |  | Target- Design Report (TARGETS) | milestone | 0d | 2007-09-28 A | 2007-09-28 A | 122253000 | 100% | 2007-10-25 | 2007-10-25 |  |  |  |  |  |  |  |  | 0 | ELOUADRHIRI L | 1 | 1 |  |  | N/A | LATIFA E |  | 2007-08-07 | 07-002 | 5 |
| 122254015M |  | BL-Design Report (BL COMPON) | milestone | 0d | 2007-09-28 A | 2007-09-28 A | 122253005M, 122254010 | 100% | 2007-10-25 | 2007-10-25 |  |  |  |  |  |  |  |  | 0 | ELOUADRHIRI L | 1 | 1 |  |  | N/A | LATIFA E |  | 2007-09-28 | 07-002 | 5 |
| 12225050 |  | BL COMPON- Dsgn of BL Shielding (BL)+ |  | 393d | 2008-03-05 A | 2009-09-28 A | 1135025 FS-20d, 12225045 FS-63d | 100% |  |  | SCIENTIST [80 h]; MECH ENG [40 h]; MECH DES [80 h] | 11,070.68 | 11,070.68 |  |  |  |  | 0 | 10853.6 | ELOUADRHIRI L | 1 | 1 | 07-027 |  | H | LATIFA E |  |  |  |  |
| 12225015 |  | Moller Polarimter Optic Dsgn (BL) |  | 282d | 2008-08-11 A | 2009-09-28 A | 9-090M | 100% |  |  | MECH ENG [120 h]; MECH DES [40 h]; CONTRB UNIV LBR [40 h] | 9,373.68 | 9,373.68 |  |  |  |  | 0 | 9410.8 | ELOUADRHIRI L | 1 | 1 | 07-027 |  | H | LATIFA E |  |  |  |  |
| 12225045 |  | BL COMPON- Beam Vac Sys (BL) |  | 246d | 2008-10-01 A | 2009-09-28 A | 9-080M FS+60d | 100% |  |  | SCIENTIST [4 h]; MECH ENG [40 h]; MECH DES [80 h] | 6,316.64 | 6,316.64 |  |  |  |  | 0 | 6121.08 | ELOUADRHIRI L | 1 | 1 | 07-027 | C | H | LATIFA E |  |  |  |  |
| 12225025 |  | Target- Layout (BL) |  | 110d | 2008-10-06 A | 2009-03-20 A | 122254015M, 9-090M FS+3d | 100% |  |  | SCIENTIST [40 h]; MECH ENG [80 h]; MECH DES [160 h]; CONTRB UNIV LBR [120 h] | 14,689.6 | 14,689.6 |  |  |  |  | 0 | 14689.6 | ELOUADRHIRI L | 1 | 1 | 07-027 |  | H | LATIFA E |  |  |  |  |
| 12225035 |  | Target- Dsgn of Cryogenic Sys (BL) |  | 98d | 2009-01-05 A | 2009-05-25 A | 12225030 FS-15d | 100% | 2009-01-05 | 2009-05-22 | MECH DES [160 h]; CONTRB UNIV LBR [80 h]; MECH ENG [80 h]; SCIENTIST [40 h] | 14,689.6 | 14,689.6 |  |  |  |  | 0 | 14689.6 | ELOUADRHIRI L | 1 | 1 |  |  | H | LATIFA E |  |  |  |  |
| 12225030 |  | Target- Vac Sys Dsgn & Mech Supprt (BL) |  | 93d | 2009-01-12 A | 2009-05-25 A | 12225025 FS-25d | 100% | 2009-01-12 | 2009-05-22 | MECH ENG [120 h]; MECH DES [220 h]; SCIENTIST [100 h]; CONTRB UNIV LBR [160 h] | 23,728 | 23,728 |  |  |  |  | 0 | 23728 | ELOUADRHIRI L | 1 | 1 |  |  | H | LATIFA E |  |  |  |  |
| 12225040 |  | Target- Dsgn Control Sys (BL)+ |  | 93d | 2009-01-12 A | 2009-05-25 A | 12225035 FS-5d | 100% | 2009-01-12 | 2009-05-22 | SCIENTIST [44 h]; CONTRB UNIV LBR [80 h]; MECH ENG [80 h]; MECH DES [160 h] | 14,946.64 | 14,946.64 |  |  |  |  | 0 | 14946.64 | ELOUADRHIRI L | 1 | 1 | 07-027 |  | H | LATIFA E |  |  |  |  |
| 12225020 |  | Moller Polarimter Mech Supprt (BL)+ |  | 153d | 2009-02-23 A | 2009-09-28 A | 12225015 FS-500d | 100% |  |  | MECH ENG [120 h]; MECH DES [40 h]; SCIENTIST [24 h]; CONTRB UNIV LBR [40 h] | 10,953.04 | 10,953.04 |  |  |  |  | 0 | 10953.04 | ELOUADRHIRI L | 1 | 1 | 07-027 |  | H | LATIFA E |  |  |  |  |
| 122254020 |  | Re-Baseline Actuals Adjustment |  | 1d | 2013-08-30 A | 2013-08-30 A |  | 100% | 2013-09-03 | 2013-09-03 | PROCUREMENT>$50K 69 NO ESCALATION | -107,087.41 |  |  |  |  | 100 |  |  |  |  |  |  |  |  |  | ADJ |  |  |  |

| ID | WBS | Activity | Type | Duration | Start | Finish | Predecessors | Complete | Planned start | Planned finish | Resources | Cost | Actual cost | Calculated Remaining Total Cost | MONTHLY EV COST | RESP - Responsibility | STRT%COMP for CM EVM | FNSH%COMP for CM EVM | CR 07-027 | WBS ASSIGNMENT | EVMS Reporting Codes | CAM RESPONSIBLE | EXPNS ACT BRIDGING FY SPLIT | CR 09-001 | ACT BRIDGING FY SPLIT | Claimed Material Divider | ReBaseline Actuals Adjustment | Planned FinishUDF | LOE Divider | LOE Multiplier | CR 07-005 | CR 09-012 | Remaining Material Cost Based on % Compl | Claimed Material Cost Based on % Complet | Initial Claimed Material Calc | Milestone Level | CR 08-058 | CR 12-012 |
| --- | --- | --- | --- | --- | --- | --- | --- | --- | --- | --- | --- | --- | --- | --- | --- | --- | --- | --- | --- | --- | --- | --- | --- | --- | --- | --- | --- | --- | --- | --- | --- | --- | --- | --- | --- | --- | --- | --- |
|  | 1 | **1.2.2.2.5.1 FARADAY CUP UPGRADE** |  |  |  |  |  |  |  |  |  |  |  |  |  |  |  |  |  |  |  |  |  |  |  |  |  |  |  |  |  |  |  |  |  |  |  |  |
|  | 2 | **1.2.2.2.5.2 MOLLER POLARIMETER UPGRADE** |  |  |  |  |  |  |  |  |  |  |  |  |  |  |  |  |  |  |  |  |  |  |  |  |  |  |  |  |  |  |  |  |  |  |  |  |
|  | 3 | **1.2.2.2.5.3 TARGETS** |  |  |  |  |  |  |  |  |  |  |  |  |  |  |  |  |  |  |  |  |  |  |  |  |  |  |  |  |  |  |  |  |  |  |  |  |
|  | 4 | **1.2.2.2.5.4 BEAMLINE COMPONENTS** |  |  |  |  |  |  |  |  |  |  |  |  |  |  |  |  |  |  |  |  |  |  |  |  |  |  |  |  |  |  |  |  |  |  |  |  |
|  | 6 | **1.2.2.2.6 INFRASTRUCTURE** |  |  | 2008-04-01 | 2013-08-30 |  |  |  |  |  |  |  |  |  |  |  |  |  |  |  |  |  |  |  |  |  |  |  |  |  |  |  |  |  |  |  |  |
| 12226010 |  | FY08 Utilities Dsgn of Connections to Cryogenic systems (Utilities) (INFSTRCTR)+ |  | 117d | 2008-04-01 A | 2008-09-15 A | 9-080M FS+120d | 100% |  |  | MECH DES [433.23 h]; MECH ENG [236.31 h] | 33,017.02 | 33,017.02 | 0 | 33017.0208 | ELOUADRHIRI L | 1 | 1 | 07-027 | 1.2.2.2.6 | N/A | LATIFA E | EXP0809 | 09-001 |  |  |  |  |  |  |  |  |  |  |  |  |  |  |
| 12226015 |  | FY08 Dsgn Mech Supprt Frames for HTCC (INFSTRCTR)+ |  | 117d | 2008-04-01 A | 2008-09-15 A | 9-080M FS+120d | 100% |  |  | MECH DES [416 h]; MECH TECH [96 h]; SCIENTIST [32 h]; MECH ENG [352 h] | 45,195.2 | 45,195.2 | 0 | 45195.2 | ELOUADRHIRI L | 1 | 1 | 07-027 | 1.2.2.2.6 | N/A | LATIFA E | EXP0809 | 09-001 | FY08-09 |  |  |  |  |  |  |  |  |  |  |  |  |  |
| 12226020 |  | FY08 Dsgn Mech Supprt Frames for Central Detector (INFSTRCTR)+ |  | 117d | 2008-04-01 A | 2008-09-15 A | 9-080M FS+120d | 100% |  |  | MECH ENG [352 h]; MECH TECH [96 h]; MECH DES [416 h]; SCIENTIST [32 h] | 45,195.2 | 45,195.2 | 0 | 45195.2 | ELOUADRHIRI L | 1 | 1 | 07-027 | 1.2.2.2.6 | N/A | LATIFA E | EXP0809 | 09-001 | FY08-09 |  |  |  |  |  |  |  |  |  |  |  |  |  |
| 12226010a |  | FY09 Utilities Dsgn of Connections to Cryogenic systems (Utilities) (INFSTRCTR)+ |  | 257d | 2008-09-16 A | 2009-09-28 A | 12226010 | 100% |  |  | MECH DES [446.77 h]; MECH ENG [243.69 h] | 35,089.7 | 35,089.7 | 0 | 35136.2557 | ELOUADRHIRI L | 1 | 1 | 07-027 | 1.2.2.2.6 | N/A | LATIFA E | EXP0809 | 09-001 |  |  |  |  |  |  |  |  |  |  |  |  |  |  |
| 12226015a |  | FY09 Dsgn Mech Supprt Frames for HTCC (INFSTRCTR)+ |  | 257d | 2008-09-16 A | 2009-09-28 A | 12226015 | 100% |  |  | MECH ENG [528 h]; MECH DES [624 h]; MECH TECH [144 h]; SCIENTIST [48 h] | 69,864.49 | 69,864.49 | 0 | 69957.12 | ELOUADRHIRI L | 1 | 1 | 07-027 | 1.2.2.2.6 | N/A | LATIFA E | EXP0809 | 09-001 | FY08-09 |  |  |  |  |  |  |  |  |  |  |  |  |  |
| 12226020a |  | FY09 Dsgn Mech Supprt Frames for Central Detector (INFSTRCTR)+ |  | 257d | 2008-09-16 A | 2009-09-28 A | 12226020 | 100% |  |  | MECH TECH [144 h]; SCIENTIST [48 h]; MECH ENG [528 h]; MECH DES [624 h] | 69,864.49 | 69,864.49 | 0 | 69957.12 | ELOUADRHIRI L | 1 | 1 | 07-027 | 1.2.2.2.6 | N/A | LATIFA E | EXP0809 | 09-001 | FY08-09 |  |  |  |  |  |  |  |  |  |  |  |  |  |
| 12226025 |  | Re-Baseline Actuals Adjustment |  | 1d | 2013-08-30 A | 2013-08-30 A |  | 100% | 2013-09-03 | 2013-09-03 | PROCUREMENT>$50K 69 NO ESCALATION | -30,146.03 |  |  |  |  |  |  |  |  |  |  |  |  |  | 100 | ADJ |  |  |  |  |  |  |  |  |  |  |  |
|  | 1 | **1.2.2.2.6.1 UTILITIES** |  |  |  |  |  |  |  |  |  |  |  |  |  |  |  |  |  |  |  |  |  |  |  |  |  |  |  |  |  |  |  |  |  |  |  |  |
|  | 2 | **1.2.2.2.6.2 MECHANICAL FRAMES** |  |  |  |  |  |  |  |  |  |  |  |  |  |  |  |  |  |  |  |  |  |  |  |  |  |  |  |  |  |  |  |  |  |  |  |  |
|  | 3 | **1.2.2.2.6.3 ASSEMBLY** |  |  |  |  |  |  |  |  |  |  |  |  |  |  |  |  |  |  |  |  |  |  |  |  |  |  |  |  |  |  |  |  |  |  |  |  |
|  | 4 | **1.2.2.2.6.4 INSTALLATION** |  |  |  |  |  |  |  |  |  |  |  |  |  |  |  |  |  |  |  |  |  |  |  |  |  |  |  |  |  |  |  |  |  |  |  |  |
|  | 3 | **1.2.2.3 HALL C** |  |  | 2006-10-02 | 2013-08-30 |  |  |  |  |  |  |  |  |  |  |  |  |  |  |  |  |  |  |  |  |  |  |  |  |  |  |  |  |  |  |  |  |
|  | 1 | **1.2.2.3.1 MAGNET** |  |  | 2006-10-02 | 2013-08-30 |  |  |  |  |  |  |  |  |  |  |  |  |  |  |  |  |  |  |  |  |  |  |  |  |  |  |  |  |  |  |  |  |
|  | 1 | **1.2.2.3.1.1 Q-1 QUADRUPOLE** |  |  | 2006-10-02 | 2013-08-30 |  |  |  |  |  |  |  |  |  |  |  |  |  |  |  |  |  |  |  |  |  |  |  |  |  |  |  |  |  |  |  |  |
| 122311007LOE |  | FY07 Overview entire PED project Q1-QUAD |  | 247d | 2006-10-02 A | 2007-09-28 A | 9-070M | 100% |  |  |  |  |  |  | 0 | FENKER H | 1 | 1 |  |  | N/A | HOWARD F |  |  |  |  |  | 2007-09-28 | 100 | 100 | 07-005 | 09-012 |  |  |  |  |  |  |
| 122311010 |  | Perform magnetic analysis and analyze tolerances Q1-QUAD |  | 247d | 2006-10-02 A | 2007-09-28 A | 9-070M | 100% |  |  | SCIENTIST [140 h]; MECH ENG [240.8 h] | 23,602.61 | 23,602.61 | 0 | 23856.594462 | FENKER H | 1 | 1 |  |  | N/A | HOWARD F |  |  |  |  |  | 2007-04-13 |  |  | 07-005 |  |  |  |  |  |  |  |
| 122311020 |  | Design LN2 shield Q1-QUAD |  | 314d | 2006-11-01 A | 2008-02-14 A | 9-070M | 100% |  |  | MECH DES [280 h]; MECH ENG [40 h] | 14,512.77 | 14,512.77 | 0 | 14882.8 | FENKER H | 1 | 1 |  |  | N/A | HOWARD F |  |  |  |  |  | 2007-01-03 |  |  | 07-005 |  |  |  |  |  |  |  |
| 122311030 |  | Design control system Q1-QUAD |  | 210d | 2007-01-02 A | 2007-10-29 A | 9-070M | 100% |  |  | PROCUREMENT<$50K 60 | 31,990 |  | 0 | 31990 | FENKER H | 1 | 1 |  |  | N/A | HOWARD F |  |  |  | 100 |  | 2006-11-28 |  |  | 07-005 |  | 0 | 31990 | 3199000 |  |  |  |
| 122311045 |  | P-1 Prepare reference design Q1-QUAD |  | 204d | 2007-01-02 A | 2007-10-19 A | 122311010 FS-80d, 122311020, 122311030 | 100% |  |  | MECH DES [96.8 h]; MECH ENG [193.6 h]; SCIENTIST [476 h] | 45,855.74 | 45,855.74 | 0 | 45619.877171 | FENKER H | 1 | 1 | 07-027 |  | N/A | HOWARD F |  |  |  |  |  | 2007-09-28 |  |  | 07-005 |  |  |  |  |  |  |  |
| 122311047 |  | Dsgn Vac Vessel Q1-QUAD |  | 138d | 2007-08-01 A | 2008-02-26 A | 9-080M | 100% |  |  | MECH DES [240 h] | 10,099.59 | 10,099.59 | 0 | 10195.2 | FENKER H | 1 | 1 | 07-027 |  | N/A | HOWARD F |  |  |  |  |  |  |  |  |  |  |  |  |  |  |  |  |
| 122311035 |  | Trial Winding of Q1 Coil Q1-QUAD |  | 288d | 2007-10-01 A | 2008-11-26 A | 122311010 | 100% | 2007-10-01 | 2008-11-25 | PROCUREMENT<$50K 60 | 35,000 |  | 0 | 35000 | FENKER H | 1 | 1 | 07-027 |  | N/A | HOWARD F |  |  |  | 100 |  | 2007-08-06 |  |  | 07-005 |  | 0 | 35000 | 3500000 |  |  |  |
| 122311908LOE |  | FY08 Overview Entire PED Proj Q1-QUAD |  | 248d | 2007-10-01 A | 2008-09-30 A | 9-080M, 122311007LOE | 100% |  |  | SCIENTIST [1036 h] | 64,511.72 | 64,511.72 | 0 | 64511.72 | FENKER H | 1 | 1 |  |  | N/A | HOWARD F |  |  |  |  |  |  | 100 | 100 |  |  |  |  |  |  |  |  |
| 122311045b |  | P-2 Prep reference Dsgn Q1-QUAD |  | 191d | 2007-10-22 A | 2008-07-31 A | 9-080M, 122311045 | 100% |  |  | MECH DES [40 h]; MECH ENG [120 h] | 9,120 | 9,120 | 0 | 9120 | FENKER H | 1 | 1 | 07-027 |  | N/A | HOWARD F |  |  |  |  |  |  |  |  |  |  |  |  |  |  |  |  |
| 122311049 |  | Dsgn Mag Supprt & Stand Q1-QUAD |  | 204d | 2007-11-01 A | 2008-08-29 A | 122311047 FS-40d, 9-080M | 100% |  |  | MECH ENG [40 h]; MECH DES [360 h] | 17,766.4 | 17,766.4 | 0 | 17766.4 | FENKER H | 1 | 1 | 07-027 |  | N/A | HOWARD F |  |  |  |  |  |  |  |  |  |  |  |  |  |  |  |  |
| 122311050M |  | Start Bid Process Q1-QUAD | milestone | 0d | 2008-06-23 A | 2008-06-23 A | 122311045M | 100% | 2008-08-07 | 2008-08-07 |  |  |  |  | 0 | FENKER H | 1 | 1 | 07-027 |  | M | HOWARD F |  |  |  |  |  |  |  |  |  |  |  |  |  | 6 |  |  |
| 122311055 |  | FY08 Bid Process P-#1 Q1-QUAD |  | 110d | 2008-06-23 A | 2008-11-26 A | 122311049 FS-40d, 122311050M | 100% | 2008-06-23 | 2008-11-25 | MECH DES [215.87 h]; TRAVEL; SUPPLIES & MATERIALS; MECH ENG [539.68 h] | 49,504.32 | 43,037.34 | 0 | 49010.9488 | FENKER H | 1 | 1 | 07-027 | 1.2.2.3.1.1 | N/A | HOWARD F | EXP0809 | 09-001 |  |  |  |  |  |  |  |  |  |  |  |  |  |  |
| 122311045M |  | Reference Dsgn Comptd Q1-QUAD | milestone | 0d | 2008-07-31 A | 2008-07-31 A | 122311045b | 100% | 2008-08-06 | 2008-08-06 |  |  |  |  | 0 | FENKER H | 1 | 1 | 07-027 |  | M | HOWARD F |  |  |  |  |  |  |  |  |  |  |  |  |  | 6 |  |  |
| 14312909LOEX |  | Q1- FY09 Proj Mngmnt H-C upgrade |  | 59d | 2008-10-01 A | 2008-12-24 A | 122311908LOE | 100% |  |  | SCIENTIST [105.25 h] | 6,763.37 | 6,763.37 | 0 | 6763.365 | FENKER H | 1 | 1 |  |  | E | HOWARD F |  |  |  |  |  |  | 100 | 100 |  |  |  |  |  |  | 08-058 | 12-012 |
| 122311056 |  | Determine Best Offer P-#2 Q1-QUAD+ |  | 126d | 2008-11-20 A | 2009-05-29 A | 122311035 FS+20d, 122311055a FS-26d | 100% |  |  |  |  |  |  | 0 | FENKER H | 1 | 1 | 07-027 |  | Z | HOWARD F |  |  |  |  |  |  |  |  |  |  |  |  |  |  |  |  |
| 122311055a |  | FY09 Bid Process P-#1 Q1-QUAD |  | 122d | 2008-11-26 A | 2009-05-29 A | 122311055 | 100% |  |  | MECH ENG [260.32 h]; TRAVEL; SUPPLIES & MATERIALS; MECH DES [104.13 h] | 24,394.96 | 21,176.08 | 0 | 24394.9584 | FENKER H | 1 | 1 | 07-027 | 1.2.2.3.1.1 | N/A | HOWARD F | EXP0809 | 09-001 |  |  |  |  |  |  |  |  |  |  |  |  |  |  |
| 122311060 |  | Re-Baseline Actuals Adjustment |  | 1d | 2013-08-30 A | 2013-08-30 A |  | 100% | 2013-09-03 | 2013-09-03 | PROCUREMENT>$50K 69 NO ESCALATION | 190,395.4 |  |  | 190395.4 |  |  |  |  |  |  |  |  |  |  | 100 | ADJ |  |  |  |  |  | 0 | 190395.4 | 19039540 |  |  |  |

| ID | WBS | Activity | Type | Duration | Start | Finish | Predecessors | Complete | Planned start | Planned finish | Resources | Cost | Actual cost | Planned FinishUDF | Calculated Remaining Total Cost | MONTHLY EV COST | RESP - Responsibility | STRT%COMP for CM EVM | FNSH%COMP for CM EVM | CR 07-005 | EVMS Reporting Codes | CAM RESPONSIBLE | Remaining Material Cost Based on % Compl | Claimed Material Cost Based on % Complet | Initial Claimed Material Calc | Claimed Material Divider | CR 07-027 | CR 08-042 | Profile change | Milestone Level | CR 07-034 | CR 08-048 | CR 09-008 | Activities with Steps | CR 10-069 | CR 11-017 | CR 11-026 | CR 12-012 | CR 12-036 | CR 11-046 | CR 13-006 | ACT BRIDGING FY SPLIT | ReBaseline Actuals Adjustment |
| --- | --- | --- | --- | --- | --- | --- | --- | --- | --- | --- | --- | --- | --- | --- | --- | --- | --- | --- | --- | --- | --- | --- | --- | --- | --- | --- | --- | --- | --- | --- | --- | --- | --- | --- | --- | --- | --- | --- | --- | --- | --- | --- | --- |
|  | 2 | **1.2.2.3.1.2 HB/Q2-3/DIPOLE** |  |  | 2006-10-02 | 2013-08-30 |  |  |  |  |  |  |  |  |  |  |  |  |  |  |  |  |  |  |  |  |  |  |  |  |  |  |  |  |  |  |  |  |  |  |  |  |  |
| 122312015 |  | Optimise coil design & analyze tolerances Q2-3/Dipole |  | 247d | 2006-10-02 A | 2007-09-28 A | 9-070M | 100% |  |  | MECH ENG [194.68 h]; MECH DES [667.2 h] | 40,882.36 | 40,882.36 | 2007-03-30 | 0 | 41600.4128 | FENKER H | 1 | 1 | 07-005 | N/A | HOWARD F |  |  |  |  |  |  |  |  |  |  |  |  |  |  |  |  |  |  |  |  |  |
| 122312060 |  | Optimize Coil Design for HB Magnet |  | 289d | 2006-10-02 A | 2007-11-30 A | 9-070M | 100% | 2006-10-02 | 2007-11-29 | MECH ENG [240 h]; MECH DES [121.2 h] | 19,984.98 | 19,984.98 | 2007-09-26 | 0 | 20195.196 | FENKER H | 1 | 1 | 07-005 | N/A | HOWARD F |  |  |  |  |  |  |  |  |  |  |  |  |  |  |  |  |  |  |  |  |  |
| 122312050 |  | Prepare reference design Q2-3/Dipole |  | 511d | 2006-11-01 A | 2008-11-21 A | 9-070M | 100% |  |  | MECH DES [160 h]; SUPPLIES & MATERIALS; MECH ENG [320 h] | 28,312.42 | 26,632.42 | 2007-08-01 | 0 | 28417.49965 | FENKER H | 1 | 1 | 07-005 | N/A | HOWARD F |  |  |  |  |  |  |  |  |  |  |  |  |  |  |  |  |  |  |  |  |  |
| 122312030 |  | Design helium vessel Q2-3/Dipole |  | 475d | 2007-01-02 A | 2008-11-21 A | 122312015 | 100% |  |  | MECH DES [131.88 h]; PROCUREMENT<$50K 60 | 35,647.77 | 5,647.77 | 2007-05-24 | 0 | 35767.1124 | FENKER H | 1 | 1 | 07-005 | N/A | HOWARD F | 0 | 30000 | 3000000 | 100 | 07-027 |  |  |  |  |  |  |  |  |  |  |  |  |  |  |  |  |
| 122312035 |  | Design LN2 shield Q2-3/Dipole |  | 312d | 2007-05-01 A | 2008-07-31 A | 122312030 FS-40d | 100% |  |  | MECH ENG [40 h]; MECH DES [480 h] | 22,805.5 | 22,805.5 | 2007-08-17 | 0 | 23476.691525 | FENKER H | 1 | 1 | 07-005 | N/A | HOWARD F |  |  |  |  | 07-027 |  |  |  |  |  |  |  |  |  |  |  |  |  |  |  |  |
| 122312045 |  | P-1 Dsgn Mag Supprt & Stand Q2-3/Dipole |  | 160d | 2007-05-01 A | 2007-12-17 A | 122312035 FS-20d | 100% |  |  | MECH ENG [16 h]; MECH DES [192 h]; PROCUREMENT<$50K 60 | 33,389.97 | 9,099.97 | 2007-09-28 | 0 | 33153.7152 | FENKER H | 1 | 1 | 07-005 | N/A | HOWARD F | 0 | 24290 | 2429000 | 100 |  |  |  |  |  |  |  |  |  |  |  |  |  |  |  |  |  |
| 122312074 |  | Dsgn Cryostat for Horiz Bender HB |  | 377d | 2007-08-01 A | 2009-02-11 A | 9-080M | 100% |  |  | MECH ENG [40 h]; MECH DES [200 h] | 11,012.87 | 11,012.87 |  | 0 | 10969.6 | FENKER H | 1 | 1 |  | N/A | HOWARD F |  |  |  |  |  |  |  |  |  |  |  |  |  |  |  |  |  |  |  |  |  |
| 122312076 |  | Dsgn quench Detection Sys for Horiz Bender |  | 157d | 2007-08-01 A | 2008-03-24 A | 9-080M | 100% |  |  | PROCUREMENT<$50K 60; MECH ENG [40 h] | 26,037.23 | 2,453.16 |  | 0 | 26057.6745 | FENKER H | 1 | 1 |  | N/A | HOWARD F | 0 | 23584.07 | 2358407 | 100 |  |  |  |  |  |  |  |  |  |  |  |  |  |  |  |  |  |
| 122312078 |  | Dsgn Supprt & Stand for Horiz Bender |  | 488d | 2007-08-01 A | 2009-07-21 A | 9-080M | 100% |  |  | MECH DES [440 h]; MECH ENG [40 h] | 21,383.42 | 21,383.42 |  | 0 | 21164.8 | FENKER H | 1 | 1 |  | N/A | HOWARD F |  |  |  |  |  |  |  |  |  |  |  |  |  |  |  |  |  |  |  |  |  |
| 122312080 |  | Prepare Preliminary Design for HB |  | 205d | 2007-08-01 A | 2008-05-30 A | 9-080M | 100% |  |  | SUPPLIES & MATERIALS; MECH ENG [120 h]; MECH DES [40 h] | 12,158.02 | 9,062.32 |  | 0 | 12215.7 | FENKER H | 1 | 1 |  | N/A | HOWARD F |  |  |  |  |  | 08-042 |  |  |  |  |  |  |  |  |  |  |  |  |  |  |  |
| 122312079 |  | CR 07-005 Procurements P-1 Dipole |  | 42d | 2008-01-01 A | 2008-03-03 A | 9-080M FS+75d | 100% | 2008-01-02 | 2008-03-03 | PROCUREMENT<$50K 60 | 32,984.68 |  |  | 0 | 32984.6835 | FENKER H | 1 | 1 |  | N/A | HOWARD F | 0 | 32984.68 | 3298468 | 100 |  |  | C |  |  |  |  |  |  |  |  |  |  |  |  |  |  |
| 122312045b |  | P-2 Dsgn Mag Supprt & Stand Q2-3/Dipole |  | 358d | 2008-01-15 A | 2009-06-19 A | 122312045 FS-120d | 100% |  |  | MECH DES [40 h] | 1,726.1 | 1,726.1 |  | 0 | 1684.587907 | FENKER H | 1 | 1 |  | N/A | HOWARD F |  |  |  |  |  |  |  |  |  |  |  |  |  |  |  |  |  |  |  |  |  |
| 122312084 |  | CR 07-005 P-2 Dipole |  | 182d | 2008-03-10 A | 2008-11-21 A | 122312079 | 100% |  |  | PROCUREMENT<$50K 60 | 32,984.68 |  |  | 0 | 32984.6835 | FENKER H | 1 | 1 |  | N/A | HOWARD F | 0 | 32984.68 | 3298468 | 100 | 07-027 |  |  |  |  |  |  |  |  |  |  |  |  |  |  |  |  |
| 122312080a |  | Prepare Reference Design for HB |  | 173d | 2008-05-30 A | 2009-02-11 A | 9-080M | 100% |  |  | PROCUREMENT<$50K 60 NO ESCALATION FY09; PROCUREMENT>$50K 69 NO ESCALATION FY09 | 90,000 |  |  | 0 | 90000 | FENKER H | 1 | 1 |  | N/A | HOWARD F | 0 | 90000 | 9000000 | 100 |  | 08-042 |  |  |  |  |  |  |  |  |  |  |  |  |  |  |  |
| 122312050M |  | Reference design completed Q2-3/Dipole | milestone | 0d | 2008-11-21 A | 2008-11-21 A | 1141015, 1141020, 122312050 | 100% | 2008-12-01 | 2008-12-01 |  |  |  | 2007-08-01 |  | 0 | FENKER H | 1 | 1 | 07-005 | M | HOWARD F |  |  |  |  |  |  | C | 5 |  |  |  |  |  |  |  |  |  |  |  |  |  |
| 122312062M |  | Start Bid Process Q2-3/Dipole | milestone | 0d | 2008-11-24 A | 2008-11-24 A | 1141015, 9-080M, 122312060, 1141020, 122312050M | 100% | 2008-12-22 | 2008-12-22 |  |  |  |  |  | 0 | FENKER H | 1 | 1 |  | M | HOWARD F |  |  |  |  |  |  |  | 6 |  |  |  |  |  |  |  |  |  |  |  |  |  |
| 122312065 |  | Bid Process P-#1 Q2-3/Dipole |  | 203d | 2008-11-24 A | 2009-09-21 A | 122312062M | 100% |  |  | MECH DES [320 h]; SUPPLIES & MATERIALS; MECH ENG [120 h]; TRAVEL | 36,741.42 | 21,686 |  | 0 | 36069.821 | FENKER H | 1 | 1 |  | H | HOWARD F |  |  |  |  |  |  |  |  |  |  |  |  |  |  |  |  |  |  |  |  |  |
| 14315050x |  | Design Cryo Reservoirs for All Mag |  | 101d | 2008-12-01 A | 2009-04-30 A | 9-090M FS+41d | 100% |  |  | MECH DES [480 h]; MECH ENG [880 h] | 77,196 | 77,196 |  | 0 | 77196 | FENKER H | 1 | 1 |  | S | HOWARD F |  |  |  |  |  |  |  |  | 07-034 | 08-048 | 09-008 | ST | 10-069 | 11-017 | 11-026 | 12-012 | 12-036F |  |  |  |  |
| 14315055x |  | Design Iron Yoke for Q2/3 and Dipole |  | 134d | 2008-12-01 A | 2009-06-17 A | 9-090M FS+41d | 100% |  |  | MECH ENG [420 h]; MECH DES [224 h] | 36,620.36 | 36,620.36 |  | 0 | 36620.36 | FENKER H | 1 | 1 |  | H | HOWARD F |  |  |  |  |  |  |  |  | 07-034 | 08-048 | 09-008 |  | 10-069 |  | 11-026 | 12-012 | 12-036F | 11-046 | 13-006F |  |  |
| 122312090 |  | Bid Process for Horiz Bender P-#1 (HB) |  | 210d | 2009-02-02 A | 2009-11-30 A | 122312074, 122312078 FS-40d, 122312080M | 100% |  |  | MECH ENG [280 h]; MECH DES [120 h] | 23,271.92 | 23,271.92 |  | 0 | 23127.6 | FENKER H | 1 | 1 |  | H | HOWARD F |  |  |  |  |  | 08-042 |  |  |  |  |  |  |  |  |  |  |  |  |  |  |  |
| 122312080M |  | Reference Dsgn for Horiz Bender Comptd | milestone | 0d | 2009-02-11 A | 2009-02-11 A | 122312080a, 122312076, 122312080 | 100% | 2009-03-02 | 2009-03-02 |  |  |  |  |  | 0 | FENKER H | 1 | 1 |  | M | HOWARD F |  |  |  |  |  | 08-042 |  | 6 |  |  |  |  |  |  |  |  |  |  |  |  |  |
| 122312070 |  | Determine Best Offer P-#2 Q2-3/Dipole |  | 1d | 2009-11-30 A | 2009-11-30 A | 122312084 FS+40d, 1141011, 122312065 | 100% |  |  |  |  |  |  |  | 0 | FENKER H | 1 | 1 |  | Z | HOWARD F |  |  |  |  | 07-027 |  | C |  |  |  |  |  |  |  |  |  |  |  |  |  |  |
| 122312095 |  | Determine Best Offer for Horiz Bender P-#2 |  | 1d | 2009-11-30 A | 2009-11-30 A | 122312090, 1141012, 122312084 | 100% |  |  |  |  |  |  |  | 0 | FENKER H | 1 | 1 |  | Z | HOWARD F |  |  |  |  | 07-027 | 08-042 | C |  |  |  |  |  |  |  |  |  |  |  |  | FY08-09 |  |
| 122312100 |  | Re-Baseline Actuals Adjustment |  | 1d | 2013-08-30 A | 2013-08-30 A |  | 100% | 2013-09-03 | 2013-09-03 | PROCUREMENT>$50K 69 NO ESCALATION | 91,235.22 |  |  |  | 91235.22 |  |  |  |  |  |  | 0 | 91235.22 | 9123522 | 100 |  |  |  |  |  |  |  |  |  |  |  |  |  |  |  |  | ADJ |

Notes:
- 122312079: Corrective Actions: 02 Mar 2007 Reduced uner 50k per Val. From 40,870 to 31,965 / (PMC)
- 122312084: Corrective Actions: 02 Mar 2007 Reduced uner 50k per Val. From 40,870 to 31,965 / (PMC)
- 122312050M: Corrective Actions: Removed Predcessor - Activity / 1141010. 23 April 2007 (PMC)
- 14315050x: Steps: Preliminary Design (done); Engineering Calculations (done); Final Drawings (done); Bid Package (done)

| ID | WBS | Activity | Type | Duration | Start | Finish | Predecessors | Complete | Planned start | Planned finish | Resources | Cost | Actual cost | Planned FinishUDF | Calculated Remaining Total Cost | MONTHLY EV COST | RESP - Responsibility | STRT%COMP for CM EVM | FNSH%COMP for CM EVM | CR 07-002 | EVMS Reporting Codes | CAM RESPONSIBLE | CR 07-027 | Remaining Material Cost Based on % Compl | Claimed Material Cost Based on % Complet | Initial Claimed Material Calc | Claimed Material Divider | ReBaseline Actuals Adjustment | CR 10-069 | CR 11-026 | CR 11-046 | CR 12-012 | CR 08-016 | EXPNS ACT BRIDGING FY SPLIT | CR 09-001 | CR 09-012 | LOE Divider | LOE Multiplier | Milestone Level |
| --- | --- | --- | --- | --- | --- | --- | --- | --- | --- | --- | --- | --- | --- | --- | --- | --- | --- | --- | --- | --- | --- | --- | --- | --- | --- | --- | --- | --- | --- | --- | --- | --- | --- | --- | --- | --- | --- | --- | --- |
|  | 2 | **1.2.2.3.2 DETECTOR** |  |  | 2007-01-02 | 2013-08-30 |  |  |  |  |  |  |  |  |  |  |  |  |  |  |  |  |  |  |  |  |  |  |  |  |  |  |  |  |  |  |  |  |  |
| 122321005 |  | P-1 Update and rescale existing drawings (WIRE CHAMB) |  | 308d | 2007-01-02 A | 2008-03-28 A | 9-070M FS+60d | 100% |  |  | SCIENTIST [80 h] | 5,002.13 | 5,002.13 | 2007-09-28 | 0 | 5013.770567 | FENKER H | 1 | 1 | 07-002 | N/A | HOWARD F |  |  |  |  |  |  |  |  |  |  |  |  |  |  |  |  |  |
| 122322005 |  | Update drawings for scintillator (HODO) |  | 387d | 2007-01-02 A | 2008-07-21 A | 9-070M FS+60d | 100% |  |  | SCIENTIST [80 h] | 4,997.94 | 4,997.94 | 2007-07-10 | 0 | 5095.402708 | FENKER H | 1 | 1 | 07-002 | N/A | HOWARD F | 07-027 |  |  |  |  |  |  |  |  |  |  |  |  |  |  |  |  |
| 122325005 |  | Prepare drawings for final block arrangements (SHWR CNTR) |  | 358d | 2007-02-23 A | 2008-07-30 A | 9-070M FS+60d | 100% |  |  | VISTNG USERS [366.8 h]; SCIENTIST [63.2 h]; TRAVEL | 12,759.46 | 10,169.46 | 2007-03-30 | 0 | 12959.436 | FENKER H | 1 | 1 | 07-002 | N/A | HOWARD F |  |  |  |  |  |  |  |  |  |  |  |  |  |  |  |  |  |
| 122323005 |  | P-1 Update existing drawings for Cerenkov (HIPRESS CRNKV) |  | 268d | 2007-03-01 A | 2008-03-28 A | 9-070M FS+174d | 100% |  |  | SCIENTIST [68 h] | 4,234.93 | 4,234.93 | 2007-09-28 | 0 | 4133.215775 | FENKER H | 1 | 1 | 07-002 | N/A | HOWARD F |  |  |  |  |  |  |  |  |  |  |  |  |  |  |  |  |  |
| 122322015 |  | P-1 Prep Drawings for Quartz hodoscope (HODO) |  | 245d | 2007-04-02 A | 2008-03-28 A | 1142025, 122322005 FS-40d, 9-070M | 100% | 2007-04-02 | 2008-03-27 | VISTNG USERS [184 h]; TRAVEL; PLABOR; SCIENTIST [28 h] | 7,357.81 | 4,857.81 | 2007-09-28 | 0 | 7358.268161 | FENKER H | 1 | 1 | 07-002 | N/A | HOWARD F |  |  |  |  |  |  |  |  |  |  |  |  |  |  |  |  |  |
| 122324005 |  | P-1 Prepare Drawings for Heavy Gas Cerenkove (LOPRESS CRNKV) |  | 193d | 2007-06-15 A | 2008-03-28 A | 9-070M | 100% |  |  | SCIENTIST [68 h] | 4,196.55 | 4,196.55 | 2007-09-28 | 0 | 4369.68 | FENKER H | 1 | 1 | 07-002 | N/A | HOWARD F | 07-027 |  |  |  |  |  |  |  |  |  |  |  |  |  |  |  |  |
| 122325020 |  | Dsgn Detector Frame (SHWR CNTR)++ |  | 446d | 2007-12-12 A | 2009-09-30 A | 122325015 FS-125d | 100% |  |  | PROCUREMENT<$50K 60 | 19,166.72 |  |  | 0 | 19166.71698 | FENKER H | 1 | 1 |  | N/A | HOWARD F | 07-027 | 0 | 19166.72 | 1916672 | 100 |  |  |  |  |  |  |  |  |  |  |  |  |
| 12232015 |  | P-2 Update & Rescale Eisting Drawings (Wire CHAMB)+ |  | 255d | 2008-06-16 A | 2009-06-24 A | 9-090M FS-100d, 122321005 | 100% |  |  | SCIENTIST [80 h] | 5,093.98 | 5,093.98 |  | 0 | 5140.8 | FENKER H | 1 | 1 |  | H | HOWARD F | 07-027 |  |  |  |  |  |  |  |  |  |  |  |  |  |  |  |  |
| 122322015b |  | P-2 Prep Drawings for Quartz Hodoscope (HODO)+ |  | 300d | 2008-06-16 A | 2009-08-27 A | 9-090M FS-100d, 122322015 FS-60d | 100% |  |  | VISTNG USERS [644 h]; TRAVEL; SCIENTIST [92 h]; PLABOR | 27,753.73 | 17,105.56 |  | 0 | 27888.0561 | FENKER H | 1 | 1 |  | H | HOWARD F | 07-027 |  |  |  |  |  |  |  |  |  |  |  |  |  |  |  |  |
| 122324005b |  | P-2 Prep Drawings for Heavy Gas Cerenkove (LOPRESS CRNKV) |  | 81d | 2008-07-14 A | 2008-11-04 A | 122324005 | 100% |  |  | SCIENTIST [12 h] | 754.61 | 754.61 |  | 0 | 771.12 | FENKER H | 1 | 1 |  | H | HOWARD F |  |  |  |  |  |  |  |  |  |  |  |  |  |  |  |  |  |
| 122323005b |  | P-2 Update Existing Drawings for Cerenkov (HIPRESS CRNKV) |  | 2d | 2008-11-03 A | 2008-11-04 A | 122323005 | 100% |  |  | SCIENTIST [12 h] | 771.12 | 771.12 |  | 0 | 771.12 | FENKER H | 1 | 1 |  | H | HOWARD F | 07-027 |  |  |  |  |  |  |  |  |  |  |  |  |  |  |  |  |
| 122325015 |  | Prep Drawings for PM & Cable Arrangement (SHWR CNTR) |  | 43d | 2009-05-25 A | 2009-07-24 A | 1142020, 9-090M FS+13d | 100% | 2009-05-26 | 2009-07-24 | VISTNG USERS [240 h]; TRAVEL; PLABOR; SCIENTIST [48 h] | 10,883.87 | 7,306.08 |  | 0 | 10883.86717 | FENKER H | 1 | 1 |  | H | HOWARD F | 07-027 |  |  |  |  |  |  |  |  |  |  |  |  |  |  |  |  |
| 122323015 |  | Update Existing Drawers for Cerenkov (HIPRESS CRNKV)+ |  | 48d | 2009-05-29 A | 2009-08-05 A | 122323005b | 100% |  |  | SCIENTIST [120 h] | 7,711.2 | 7,711.2 |  | 0 | 7711.2 | FENKER H | 1 | 1 |  | H | HOWARD F | 07-027 |  |  |  |  |  |  |  |  |  |  |  |  |  |  |  |  |
| 122324015 |  | Prep Drawings for Heavy Gas Cerenkove (LOPRESS CRNKV)+ |  | 55d | 2009-05-29 A | 2009-08-14 A | 122324005b FS+1d | 100% |  |  | SCIENTIST [120 h] | 7,711.2 | 7,711.2 |  | 0 | 7711.2 | FENKER H | 1 | 1 |  | H | HOWARD F | 07-027 |  |  |  |  |  |  |  |  |  |  |  |  |  |  |  |  |
| 12232020 |  | P-3 Update & Rescale Existing Drawings (Wire CHAMB)+ |  | 56d | 2009-07-01 A | 2009-09-18 A | 12232015 FS-100d, 122325005 FS-15d | 100% |  |  | SCIENTIST [40 h] | 2,570.4 | 2,570.4 |  | 0 | 2570.4 | FENKER H | 1 | 1 |  | H | HOWARD F | 07-027 |  |  |  |  |  |  |  |  |  |  |  |  |  |  |  |  |
| 122325025 |  | Re-Baseline Actuals Adjustment |  | 1d | 2013-08-30 A | 2013-08-30 A |  | 100% | 2013-09-03 | 2013-09-03 | PROCUREMENT>$50K 69 NO ESCALATION | -15,172.56 |  |  |  |  |  |  |  |  |  |  |  |  |  |  | 100 | ADJ |  |  |  |  |  |  |  |  |  |  |  |
|  | 1 | **1.2.2.3.2.1 WIRE CHAMBERS** |  |  |  |  |  |  |  |  |  |  |  |  |  |  |  |  |  |  |  |  |  |  |  |  |  |  |  |  |  |  |  |  |  |  |  |  |  |
|  | 2 | **1.2.2.3.2.2 HODOSCOPES** |  |  |  |  |  |  |  |  |  |  |  |  |  |  |  |  |  |  |  |  |  |  |  |  |  |  |  |  |  |  |  |  |  |  |  |  |  |
|  | 3 | **1.2.2.3.2.3 HIGH PRESSURE CERENKOV (Atm.Press.Cerenkov)** |  |  |  |  |  |  |  |  |  |  |  |  |  |  |  |  |  |  |  |  |  |  |  |  |  |  |  |  |  |  |  |  |  |  |  |  |  |
|  | 4 | **1.2.2.3.2.4 LOW PRESSURE CERENKOV (Heavy Gas Cerenkov))** |  |  |  |  |  |  |  |  |  |  |  |  |  |  |  |  |  |  |  |  |  |  |  |  |  |  |  |  |  |  |  |  |  |  |  |  |  |
|  | 5 | **1.2.2.3.2.5 SHOWER COUNTER** |  |  |  |  |  |  |  |  |  |  |  |  |  |  |  |  |  |  |  |  |  |  |  |  |  |  |  |  |  |  |  |  |  |  |  |  |  |
|  | 6 | **1.2.2.3.2.6 AEROGEL CERENKOV** |  |  |  |  |  |  |  |  |  |  |  |  |  |  |  |  |  |  |  |  |  |  |  |  |  |  |  |  |  |  |  |  |  |  |  |  |  |
|  | 7 | **1.2.2.3.2.7 TRD** |  |  |  |  |  |  |  |  |  |  |  |  |  |  |  |  |  |  |  |  |  |  |  |  |  |  |  |  |  |  |  |  |  |  |  |  |  |
|  | 8 | **1.2.2.3.2.8 DETECTOR FRAME** |  |  |  |  |  |  |  |  |  |  |  |  |  |  |  |  |  |  |  |  |  |  |  |  |  |  |  |  |  |  |  |  |  |  |  |  |  |
|  | 3 | **1.2.2.3.3 COMPUTING** |  |  |  |  |  |  |  |  |  |  |  |  |  |  |  |  |  |  |  |  |  |  |  |  |  |  |  |  |  |  |  |  |  |  |  |  |  |
|  | 1 | **1.2.2.3.3.1 DAQ** |  |  |  |  |  |  |  |  |  |  |  |  |  |  |  |  |  |  |  |  |  |  |  |  |  |  |  |  |  |  |  |  |  |  |  |  |  |
|  | 2 | **1.2.2.3.3.2 SLOW CONTROLS** |  |  |  |  |  |  |  |  |  |  |  |  |  |  |  |  |  |  |  |  |  |  |  |  |  |  |  |  |  |  |  |  |  |  |  |  |  |
|  | 4 | **1.2.2.3.4 ELECTRONICS** |  |  |  |  |  |  |  |  |  |  |  |  |  |  |  |  |  |  |  |  |  |  |  |  |  |  |  |  |  |  |  |  |  |  |  |  |  |
|  | 1 | **1.2.2.3.4.1 FAST ELECTRONICS** |  |  |  |  |  |  |  |  |  |  |  |  |  |  |  |  |  |  |  |  |  |  |  |  |  |  |  |  |  |  |  |  |  |  |  |  |  |
|  | 2 | **1.2.2.3.4.2 POWER SUPPLIES & PROBES** |  |  |  |  |  |  |  |  |  |  |  |  |  |  |  |  |  |  |  |  |  |  |  |  |  |  |  |  |  |  |  |  |  |  |  |  |  |
|  | 5 | **1.2.2.3.5 BEAMLINE** |  |  |  |  |  |  |  |  |  |  |  |  |  |  |  |  |  |  |  |  |  |  |  |  |  |  |  |  |  |  |  |  |  |  |  |  |  |
|  | 1 | **1.2.2.3.5.1 MOELLER** |  |  |  |  |  |  |  |  |  |  |  |  |  |  |  |  |  |  |  |  |  |  |  |  |  |  |  |  |  |  |  |  |  |  |  |  |  |
|  | 2 | **1.2.2.3.5.2 COMPTON** |  |  |  |  |  |  |  |  |  |  |  |  |  |  |  |  |  |  |  |  |  |  |  |  |  |  |  |  |  |  |  |  |  |  |  |  |  |
|  | 3 | **1.2.2.3.5.3 MAPPING** |  |  |  |  |  |  |  |  |  |  |  |  |  |  |  |  |  |  |  |  |  |  |  |  |  |  |  |  |  |  |  |  |  |  |  |  |  |
|  | 4 | **1.2.2.3.5.4 SCATTERING CHAMBER** |  |  |  |  |  |  |  |  |  |  |  |  |  |  |  |  |  |  |  |  |  |  |  |  |  |  |  |  |  |  |  |  |  |  |  |  |  |
|  | 5 | **1.2.2.3.5.5 BEAM PIPE & STANDS** |  |  |  |  |  |  |  |  |  |  |  |  |  |  |  |  |  |  |  |  |  |  |  |  |  |  |  |  |  |  |  |  |  |  |  |  |  |
|  | 6 | **1.2.2.3.5.6 MAGNET POWER SUPPLY** |  |  |  |  |  |  |  |  |  |  |  |  |  |  |  |  |  |  |  |  |  |  |  |  |  |  |  |  |  |  |  |  |  |  |  |  |  |
|  | 6 | **1.2.2.3.6 INFRASTRUCTURE** |  |  | 2006-11-01 | 2013-08-30 |  |  |  |  |  |  |  |  |  |  |  |  |  |  |  |  |  |  |  |  |  |  |  |  |  |  |  |  |  |  |  |  |  |
| 122363010 |  | Prepare preliminary drawings (SHLD HOUSE) |  | 118d | 2006-11-01 A | 2007-04-27 A | 9-070M | 100% |  |  | MECH ENG [64.44 h]; MECH DES [71.48 h]; PROCUREMENT<$50K 60 | 17,789.49 | 7,144.49 | 2007-02-05 | 0 | 17793.70012 | FENKER H | 1 | 1 | 07-002 | N/A | HOWARD F |  | 0 | 10645 | 1064500 | 100 |  |  |  |  |  |  |  |  |  |  |  |  |
| 122362010 |  | Hire subcontructor to prepare preliminmary design (SUP STRUCT) |  | 82d | 2007-01-02 A | 2007-04-27 A | 9-070M | 100% |  |  | PROCUREMENT<$50K 60 | 10,320 |  | 2007-02-14 | 0 | 10320 | FENKER H | 1 | 1 | 07-002 | N/A | HOWARD F |  | 0 | 10320 | 1032000 | 100 |  |  |  |  |  |  |  |  |  |  |  |  |
| 122361010 |  | P-1 Dsgn Vac Sys (ENG&DES)+ |  | 160d | 2007-04-13 A | 2007-11-30 A | 9-070M FS+130d | 100% | 2007-04-13 | 2007-11-29 | MECH DES [220 h]; MECH ENG [110 h]; SUPPLIES & MATERIALS | 18,117.98 | 16,053.98 | 2007-09-28 | 0 | 18080.891846 | FENKER H | 1 | 1 | 07-002 | N/A | HOWARD F | 07-027 |  |  |  |  |  | 10-069 | 11-026 | 11-046 | 12-012 |  |  |  |  |  |  |  |
| 122361015 |  | P-1 Dsgn Cryogenic Sys (ENG&DES)+ |  | 161d | 2007-04-13 A | 2007-11-30 A | 9-070M FS+130d | 100% |  |  | SUPPLIES & MATERIALS; MECH ENG [72 h]; MECH DES [148 h] | 12,742.02 | 10,678.02 | 2007-09-28 | 0 | 12717.192062 | FENKER H | 1 | 1 | 07-002 | N/A | HOWARD F | 07-027 |  |  |  |  |  |  |  |  |  |  |  |  |  |  |  |  |
| 122362015 |  | Approve preliminary design (SUP STRUCT) |  | 35d | 2007-04-27 A | 2007-06-15 A | 122362010 | 100% |  |  | MECH ENG [40 h]; MECH DES [40 h]; TRAVEL | 6,294.8 | 4,230.8 | 2007-02-22 | 0 | 6307.6 | FENKER H | 1 | 1 | 07-002 | N/A | HOWARD F |  |  |  |  |  |  |  |  |  |  |  |  |  |  |  |  |  |
| 122363015 |  | Approve preliminary design (SHLD HOUSE) |  | 35d | 2007-04-27 A | 2007-06-15 A | 122363010 | 100% |  |  | TRAVEL; MECH ENG [40 h]; MECH DES [40 h] | 6,298.8 | 4,230.8 | 2007-02-12 | 0 | 6311.6 | FENKER H | 1 | 1 | 07-002 | N/A | HOWARD F |  |  |  |  |  |  |  |  |  |  |  |  |  |  |  |  |  |
| 12236020 |  | Dsgn Scattering Chamb (ENG&DES)+ |  | 362d | 2007-12-10 A | 2009-05-29 A | 9-090M | 100% |  |  | MECH DES [80 h]; SUPPLIES & MATERIALS; MECH ENG [40 h] | 8,085.59 | 5,955.95 |  | 0 | 8189.23522 | FENKER H | 1 | 1 |  | N/A | HOWARD F | 07-027 |  |  |  |  |  | 10-069 | 11-026 | 11-046 | 12-012 |  |  |  |  |  |  |  |
| 12236025 |  | Dsgn Beam Pipe & Stands (ENG&DES)+ |  | 445d | 2007-12-11 A | 2009-09-28 A | 9-090M | 100% |  |  | MECH ENG [80 h]; MECH DES [160 h]; SUPPLIES & MATERIALS | 14,081.05 | 11,951.41 |  | 0 | 14248.83522 | FENKER H | 1 | 1 |  | N/A | HOWARD F | 07-027 |  |  |  |  |  | 10-069 | 11-026 | 11-046 | 12-012 |  |  |  |  |  |  |  |
| 122362020 |  | Produce detailed design and drawings (SUP STRUCT) |  | 181d | 2008-01-15 A | 2008-09-30 A | 9-080M FS+62.5d, 122362015 | 100% |  |  | PROCUREMENT<$50K 60; MECH ENG [113.6 h]; MECH DES [280.4 h] | 46,281.76 | 18,936.41 | 2007-09-28 | 0 | 46281.766 | FENKER H | 1 | 1 | 07-002 | N/A | HOWARD F | 07-027 | 0 | 27345.35 | 2734535 | 100 |  |  |  |  |  |  |  |  |  |  |  |  |
| 122363020 |  | Prepare detailed design and drawings (SHLD HOUSE) |  | 181d | 2008-01-15 A | 2008-09-30 A | 122363015, 9-080M FS+63d | 100% |  |  | MECH ENG [80 h]; MECH DES [80 h]; PROCUREMENT<$50K 60 | 30,712.03 | 8,345.6 | 2007-09-28 | 0 | 30712.0325 | FENKER H | 1 | 1 | 07-002 | N/A | HOWARD F | 07-027 | 0 | 22366.43 | 2236643 | 100 |  |  |  |  |  |  |  |  |  |  |  |  |
| 12236030 |  | PROC Continue Reference Dsgn & Drawings (SUP STRUCT) |  | 94d | 2008-07-14 A | 2008-11-21 A | 122362020 FS-160d | 100% |  |  | PROCUREMENT<$50K 60 NO ESCALATION FY09 | 25,560.16 |  |  | 0 | 25560.163 | FENKER H | 1 | 1 |  | H | HOWARD F | 07-027 | 0 | 25560.16 | 2556016 | 100 |  |  |  |  |  | 08-016 | EXP0809 | 09-001 | 09-012 |  |  |  |
| 12236030a |  | FY08 LAB/EXP Continue Reference Dsgn & Drawings (SUP STRUCT) |  | 70d | 2008-07-14 A | 2008-10-20 A | 122362020 | 100% |  |  | MECH DES [115 h]; MECH ENG [50.6 h]; TRAVEL | 9,252.21 | 8,065.52 |  | 0 | 9200.994 | FENKER H | 1 | 1 |  | H | HOWARD F | 07-027 |  |  |  |  |  |  |  |  |  | 08-016 | EXP0809 | 09-001 |  |  |  |  |
| 12236830LOE |  | FY09 Coordinate All SHMS Compnts with Supprt Struct (ENG&DES)+ |  | 189d | 2008-10-01 A | 2009-07-08 A | 9-090M | 100% |  |  | MECH ENG [80 h]; MECH DES [160 h]; TRAVEL; PLABOR; PROCUREMENT<$50K 60 | 35,225.74 | 12,119.2 |  | 0 | 35225.742138 | FENKER H | 1 | 1 |  | E | HOWARD F | 07-027 | 0 | 15386.61 | 1538661 | 100 |  |  |  |  |  |  |  |  |  | 100 | 100 |  |
| 12236045 |  | PROC Continue Reference Dsgn & Drawings (SHLD HOUSE) |  | 167d | 2008-10-20 A | 2009-06-24 A | 122363020 FS-103d | 100% |  |  | PROCUREMENT<$50K 60 NO ESCALATION FY09 | 21,298.42 |  |  | 0 | 21298.416 | FENKER H | 1 | 1 |  | H | HOWARD F | 07-027 | 0 | 21298.42 | 2129842 | 100 |  |  |  |  |  | 08-016 | EXP0809 | 09-001 | 09-012 |  |  |  |
| 12236045a |  | FY08 LAB/EXP Continue Reference Dsgn & Drawings (SHLD HOUSE) |  | 129d | 2008-10-20 A | 2009-04-30 A | 122363020 | 100% |  |  | MECH DES [42.67 h]; MECH ENG [42.67 h]; TRAVEL | 5,694.11 | 4,593.42 |  | 0 | 5552.0244 | FENKER H | 1 | 1 |  | H | HOWARD F | 07-027 |  |  |  |  |  |  |  |  |  | 08-016 | EXP0809 | 09-001 |  |  |  |  |
| 12236045b |  | FY09 LAB/EXP Continue Reference Dsgn & Drawings (SHLD HOUSE) |  | 129d | 2008-10-20 A | 2009-04-30 A | 12236045a FS-15d | 100% |  |  | TRAVEL; MECH DES [37.33 h]; MECH ENG [37.33 h] | 5,012.41 | 4,018.58 |  | 0 | 5012.4045 | FENKER H | 1 | 1 |  | H | HOWARD F | 07-027 |  |  |  |  |  |  |  |  |  | 08-016 | EXP0809 | 09-001 |  |  |  |  |
| 12236030b |  | FY09 LAB/EXP Continue Reference Dsgn & Drawings (SUP STRUCT) |  | 16d | 2008-10-31 A | 2008-11-21 A | 12236030a | 100% |  |  | TRAVEL; MECH DES [85 h]; MECH ENG [37.4 h] | 7,017.99 | 6,112.89 |  | 0 | 7017.994 | FENKER H | 1 | 1 |  | H | HOWARD F | 07-027 |  |  |  |  |  |  |  |  |  | 08-016 | EXP0809 | 09-001 |  |  |  |  |
| 12236010b |  | P-2 Dsgn Vac Sys (ENG&DES)+ |  | 163d | 2008-12-01 A | 2009-07-30 A | 122361010, 9-090M FS-100d | 100% |  |  | SUPPLIES & MATERIALS; MECH DES [19.6 h]; MECH ENG [0.4 h] | 3,014.42 | 884.78 |  | 0 | 3014.42322 | FENKER H | 1 | 1 |  | H | HOWARD F | 07-027 |  |  |  |  |  | 10-069 | 11-026 | 11-046 | 12-012 |  |  |  |  |  |  |  |
| 12236015b |  | P-2 Dsgn Cryogenic Sys (ENG&DES)+ |  | 206d | 2008-12-01 A | 2009-09-29 A | 9-090M FS-100d, 122361015 | 100% |  |  | MECH DES [12 h]; SUPPLIES & MATERIALS; MECH ENG [8 h] | 3,166.2 | 1,036.56 |  | 0 | 3166.19522 | FENKER H | 1 | 1 |  | H | HOWARD F | 07-027 |  |  |  |  |  |  |  |  |  |  |  |  |  |  |  |  |
| 12236035 |  | Prep Bid Packages (SUP STRUCT) |  | 70d | 2009-06-15 A | 2009-09-22 A | 12236030, 12236030b | 100% |  |  | MECH DES [160 h]; SUPPLIES & MATERIALS; MECH ENG [80 h] | 15,846.06 | 12,119.2 |  | 0 | 15846.061635 | FENKER H | 1 | 1 |  | H | HOWARD F | 07-027 |  |  |  |  |  |  |  |  |  |  |  |  |  |  |  |  |
| 12236050 |  | Prep Bid Packages (SHLD HOUSE) |  | 58d | 2009-07-01 A | 2009-09-22 A | 12236045 FS-200d, 12236045b FS-200d | 100% |  |  | MECH DES [80 h]; SUPPLIES & MATERIALS; MECH ENG [80 h] | 12,338.86 | 8,612 |  | 0 | 12338.861635 | FENKER H | 1 | 1 |  | H | HOWARD F | 07-027 |  |  |  |  |  |  |  |  |  |  |  |  |  |  |  |  |
| 12236035M |  | Start Bid Process (SUP STRUCT) | milestone | 0d | 2009-11-02 A | 2009-11-02 A | 12236035 FS+40d | 100% | 2009-12-01 | 2009-12-01 |  |  |  |  |  | 0 | FENKER H | 1 | 1 |  | M | HOWARD F | 07-027 |  |  |  |  |  |  |  |  |  |  |  |  |  |  |  | 6 |
| 12236055M |  | Start Bid Process (SHLD HOUSE) | milestone | 0d | 2009-11-02 A | 2009-11-02 A | 12236050 FS+40d | 100% | 2009-12-01 | 2009-12-01 |  |  |  |  |  | 0 | FENKER H | 1 | 1 |  | M | HOWARD F | 07-027 |  |  |  |  |  |  |  |  |  |  |  |  |  |  |  | 6 |
| 12236040 |  | Determine Best Offer (SUP STRUCT)+ |  | 5d | 2009-12-14 A | 2009-12-21 A | 12236035M | 100% | 2009-12-14 | 2009-12-18 | MECH ENG [40 h]; MECH DES [40 h]; TRAVEL | 6,573.24 | 4,443.6 |  | 0 | 6435.63522 | FENKER H | 1 | 1 |  | H | HOWARD F | 07-027 |  |  |  |  |  |  |  |  |  |  |  |  |  |  |  |  |
| 12236060 |  | Determine Best Offer (SHLD HOUSE)+ |  | 5d | 2009-12-14 A | 2009-12-21 A | 12236055M | 100% | 2009-12-14 | 2009-12-18 | MECH ENG [40 h]; MECH DES [40 h]; TRAVEL | 6,573.24 | 4,443.6 |  | 0 | 6435.63522 | FENKER H | 1 | 1 |  | H | HOWARD F | 07-027 |  |  |  |  |  |  |  |  |  |  |  |  |  |  |  |  |
| 122363025 |  | Re-Baseline Actuals Adjustment |  | 1d | 2013-08-30 A | 2013-08-30 A |  | 100% | 2013-09-03 | 2013-09-03 | PROCUREMENT>$50K 69 NO ESCALATION | -38,064.45 |  |  |  |  |  |  |  |  |  |  |  |  |  |  | 100 | ADJ |  |  |  |  |  |  |  |  |  |  |  |

| ID | WBS | Activity | Type | Duration | Start | Finish | Predecessors | Complete | Planned start | Planned finish | Constraint | Resources | Cost | Actual cost | LOE Divider | LOE Multiplier | Calculated Remaining Total Cost | MONTHLY EV COST | RESP - Responsibility | STRT%COMP for CM EVM | FNSH%COMP for CM EVM | HALL D Related Milestones | CR 07-024 | EVMS Reporting Codes | CAM RESPONSIBLE | CR 08-058 | CR 11-004 | CR 11-006 | CR 11-036 | Remaining Material Cost Based on % Compl | Claimed Material Cost Based on % Complet | Initial Claimed Material Calc | Claimed Material Divider | ReBaseline Actuals Adjustment | Planned FinishUDF | CR 07-014 | Milestone Level | CR 07-027 | CR 09-012 | CR 11-026 | CR 12-054 |
| --- | --- | --- | --- | --- | --- | --- | --- | --- | --- | --- | --- | --- | --- | --- | --- | --- | --- | --- | --- | --- | --- | --- | --- | --- | --- | --- | --- | --- | --- | --- | --- | --- | --- | --- | --- | --- | --- | --- | --- | --- | --- |
|  | 1 | **1.2.2.3.6.1 ENGINEERING & DESIGN** |  |  |  |  |  |  |  |  |  |  |  |  |  |  |  |  |  |  |  |  |  |  |  |  |  |  |  |  |  |  |  |  |  |  |  |  |  |  |  |
|  | 2 | **1.2.2.3.6.2 SUPPORT STRUCTURE** |  |  |  |  |  |  |  |  |  |  |  |  |  |  |  |  |  |  |  |  |  |  |  |  |  |  |  |  |  |  |  |  |  |  |  |  |  |  |  |
|  | 3 | **1.2.2.3.6.3 SHIELD HOUSE** |  |  |  |  |  |  |  |  |  |  |  |  |  |  |  |  |  |  |  |  |  |  |  |  |  |  |  |  |  |  |  |  |  |  |  |  |  |  |  |
|  | 4 | **1.2.2.3.6.4 CRYOGENIC SYSTEM** |  |  |  |  |  |  |  |  |  |  |  |  |  |  |  |  |  |  |  |  |  |  |  |  |  |  |  |  |  |  |  |  |  |  |  |  |  |  |  |
|  | 5 | **1.2.2.3.6.5 VACUUM SYSTEM** |  |  |  |  |  |  |  |  |  |  |  |  |  |  |  |  |  |  |  |  |  |  |  |  |  |  |  |  |  |  |  |  |  |  |  |  |  |  |  |
|  | 6 | **1.2.2.3.6.6 CABLING** |  |  |  |  |  |  |  |  |  |  |  |  |  |  |  |  |  |  |  |  |  |  |  |  |  |  |  |  |  |  |  |  |  |  |  |  |  |  |  |
|  | 7 | **1.2.2.3.6.7 SOS PIVOT MODIFICATION** |  |  |  |  |  |  |  |  |  |  |  |  |  |  |  |  |  |  |  |  |  |  |  |  |  |  |  |  |  |  |  |  |  |  |  |  |  |  |  |
|  | 8 | **1.2.2.3.6.8 INSTALLATION** |  |  |  |  |  |  |  |  |  |  |  |  |  |  |  |  |  |  |  |  |  |  |  |  |  |  |  |  |  |  |  |  |  |  |  |  |  |  |  |
|  | 3 | **1.2.3 HALL D** |  |  | 2006-10-02 | 2013-08-30 |  |  |  |  |  |  |  |  |  |  |  |  |  |  |  |  |  |  |  |  |  |  |  |  |  |  |  |  |  |  |  |  |  |  |  |
|  | 1 | **1.2.3.1 SOLENOID** |  |  | 2008-12-02 | 2013-08-30 |  |  |  |  |  |  |  |  |  |  |  |  |  |  |  |  |  |  |  |  |  |  |  |  |  |  |  |  |  |  |  |  |  |  |  |
| 151009E5 |  | FY09 Travel (SOLENOID) |  | 15d | 2008-12-02 A | 2008-12-22 A | 9-090M | 100% |  |  |  | TRAVEL | 286.74 |  | 100 | 100 | 0 | 286.74 | CHUDAKOV | 1 | 1 | D | 07-024 | E | EUGENE C | 08-058 | 11-004 | 11-006 | 11-036 |  |  |  |  |  |  |  |  |  |  |  |  |
| 1231000 |  | Re-Baseline Actuals Adjustment |  | 1d | 2013-08-30 A | 2013-08-30 A |  | 100% | 2013-09-03 | 2013-09-03 |  | PROCUREMENT>$50K 69 NO ESCALATION | 165.15 |  |  |  |  | 165.15 |  |  |  |  |  |  |  |  |  |  |  | 0 | 165.15 | 16515 | 100 | ADJ |  |  |  |  |  |  |  |
|  | 2 | **1.2.3.2 DETECTORS** |  |  | 2006-10-02 | 2013-08-30 |  |  |  |  |  |  |  |  |  |  |  |  |  |  |  |  |  |  |  |  |  |  |  |  |  |  |  |  |  |  |  |  |  |  |  |
| 123211010 |  | Fall Progress updates including safety assessment at Hall D collaboration meeting |  | 12d | 2006-10-16 A | 2006-10-31 A | 9-070M FS+32d | 100% |  |  |  |  |  |  |  |  |  | 0 | CHUDAKOV | 1 | 1 |  |  | N/A | EUGENE C |  |  |  |  |  |  |  |  |  | 2006-11-30 | 07-014 |  |  |  |  |  |
| 123211010M |  | Fall Design updates based on collaboration assessment | milestone | 0d | 2006-10-31 A | 2006-10-31 A | 123211010 FS+11d | 100% | 2006-12-15 | 2006-12-15 |  |  |  |  |  |  |  | 0 | CHUDAKOV | 1 | 1 |  |  | N/A | EUGENE C |  |  |  |  |  |  |  |  |  | 2006-12-15 | 07-014 | 9 |  |  |  |  |
| 123211020 |  | Spring Progress updates including safety assessment at Hall D collaboration meeting |  | 8d | 2007-03-02 A | 2007-03-13 A | 123211010M FS+87d | 100% |  |  |  |  |  |  |  |  |  | 0 | CHUDAKOV | 1 | 1 |  |  | N/A | EUGENE C |  |  |  |  |  |  |  |  |  | 2007-05-11 | 07-014 |  |  |  |  |  |
| 123211020M |  | Spring Safety Design Report updates based on collaboration assessment | milestone | 0d | 2007-03-13 A | 2007-03-13 A | 123211020 FS+2d | 100% | 2007-05-15 | 2007-05-15 |  |  |  |  |  |  |  | 0 | CHUDAKOV | 1 | 1 |  |  | N/A | EUGENE C |  |  |  |  |  |  |  |  |  | 2007-05-15 | 07-014 | 5 |  |  |  |  |
|  | 1 | **1.2.3.2.1 TRACKING** |  |  | 2006-10-02 | 2013-08-30 |  |  |  |  |  |  |  |  |  |  |  |  |  |  |  |  |  |  |  |  |  |  |  |  |  |  |  |  |  |  |  |  |  |  |  |
| 123211015 |  | Interim Design and Safety Assessment of drift chambers |  | 9d | 2007-03-01 A | 2007-03-13 A | 1152005 FS-100d, 9-070M FS+108d | 100% |  |  |  |  |  |  |  |  |  | 0 | CHUDAKOV | 1 | 1 |  |  | N/A | EUGENE C |  |  |  |  |  |  |  |  |  | 2007-05-22 | 07-014 |  |  |  |  |  |
| 123211015M |  | Interim Drift chamber design requirements updated | milestone | 0d | 2007-04-27 A | 2007-04-27 A | 123211015 FS+13d | 100% | 2007-04-16 | 2007-04-16 |  |  |  |  |  |  |  | 0 | CHUDAKOV | 1 | 1 |  |  | N/A | EUGENE C |  |  |  |  |  |  |  |  |  | 2007-06-11 | 07-014 | 9 |  |  |  |  |
| 12321017 |  | Final Dsgn & Safty Assessmnt of Drift Chambs |  | 49d | 2009-01-05 A | 2009-03-16 A | 123213010, 123211020M, 123212035 FS-40d, 123211055 FS-40d | 100% |  |  |  |  |  |  |  |  |  | 0 | CHUDAKOV | 1 | 1 |  |  | Z | EUGENE C |  |  |  |  |  |  |  |  |  |  |  |  | 07-027 |  |  |  |
| 12321018M |  | Drift Chamb Dsgn Rquirmnts Finalized++ | milestone | 0d | 2009-03-16 A | 2009-03-16 A | 12321017 | 100% | 2009-04-30 | 2009-04-30 |  |  |  |  |  |  |  | 0 | CHUDAKOV | 1 | 1 | D |  | M | EUGENE C |  |  |  |  |  |  |  |  |  |  |  | 6 | 07-027 |  |  |  |
|  | 1 | **1.2.3.2.1.1 FORWARD CHAMBERS** |  |  | 2006-11-01 | 2013-08-30 |  |  |  |  |  |  |  |  |  |  |  |  |  |  |  |  |  |  |  |  |  |  |  |  |  |  |  |  |  |  |  |  |  |  |  |
| 123211005 |  | Develop FDC design (FWD CHAMB) |  | 57d | 2006-11-01 A | 2007-02-01 A | 9-070M | 100% | 2006-11-01 | 2007-01-31 |  | CONTRB UNIV LBR [461.2 h]; MECH TECH [252.2 h] | 10,032.52 | 10,032.52 |  |  | 0 | 10032.510709 | CHUDAKOV | 1 | 1 |  |  | N/A | EUGENE C |  |  |  |  |  |  |  |  |  | 2007-09-28 | 07-014 |  |  | 09-012 |  |  |
| 12321105A |  | Develop FDC design (FWD CHAMB) |  | 168d | 2007-02-01 A | 2007-09-28 A | 123211005 | 100% |  |  | start on or after 2007-02-02 | ELEC ENG [298.8 h]; MECH DES [733.2 h] | 50,113.94 | 50,113.94 |  |  | 0 | 50101.177707 | CHUDAKOV | 1 | 1 |  |  | N/A | EUGENE C |  |  |  |  |  |  |  |  |  | 2007-09-28 | 07-014 |  |  | 09-012 |  |  |
| 123211025 |  | Specify All FDC Chamb Matrl's |  | 86d | 2007-11-01 A | 2008-03-14 A | 123211015M, 12321105A | 100% |  |  |  | CONTRB UNIV LBR [400 h] |  |  |  |  |  | 0 | CHUDAKOV | 1 | 1 |  |  | N/A | EUGENE C |  |  |  |  |  |  |  |  |  |  |  |  |  |  |  |  |
| 123211035 |  | Comp FDC Layout & Dsgn of on-board Electrnc's |  | 171d | 2007-11-01 A | 2008-07-15 A | 12321105A | 100% |  |  |  | MECH TECH [400 h] | 15,680 | 15,680 |  |  | 0 | 15680 | CHUDAKOV | 1 | 1 |  |  | N/A | EUGENE C |  |  |  |  |  |  |  |  |  |  |  |  |  |  |  |  |
| 123211045 |  | Finalize FDC Cable Spec's, Connectors, Routing, & Packing Decisions |  | 170d | 2007-11-01 A | 2008-07-14 A | 12321105A | 100% |  |  |  | MECH TECH [308 h] | 12,073.6 | 12,073.6 |  |  | 0 | 12073.6 | CHUDAKOV | 1 | 1 |  |  | N/A | EUGENE C |  |  |  |  |  |  |  |  |  |  |  |  |  |  |  |  |
| 123211030 |  | Detail FDC Final Procedure for Chamb Wire Stringing, Constrctn, & Assy |  | 193d | 2007-12-03 A | 2008-09-12 A | 12321105A | 100% |  |  |  | CONTRB UNIV LBR [400 h] |  |  |  |  |  | 0 | CHUDAKOV | 1 | 1 |  |  | N/A | EUGENE C |  |  |  |  |  |  |  |  |  |  |  |  |  |  |  |  |
| 123211050 |  | Comp Final FDC Drawings |  | 187d | 2008-01-07 A | 2008-09-30 A | 123211025, 123211040, 123211030, 123211035, 123211045 | 100% |  |  |  | MECH ENG [880 h]; CONTRB UNIV LBR [520 h] | 54,419.2 | 54,419.2 |  |  | 0 | 54419.2 | CHUDAKOV | 1 | 1 |  |  | N/A | EUGENE C |  |  |  |  |  |  |  |  |  |  |  |  |  |  |  |  |
| 123211040 |  | Dsgn FDC Gas Handling Sys |  | 194d | 2008-02-29 A | 2008-12-03 A | 12321105A | 100% |  |  |  | MECH TECH [400 h] | 15,793.4 | 15,793.4 |  |  | 0 | 15680 | CHUDAKOV | 1 | 1 |  |  | N/A | EUGENE C |  |  |  |  |  |  |  |  |  |  |  |  |  |  |  |  |
| 123211055 |  | Detail FDC Final Procedures for Component Quality Control & Acceptance |  | 204d | 2008-07-28 A | 2009-05-25 A | 123211050 | 100% | 2008-07-28 | 2009-05-22 |  | CONTRB UNIV LBR [764 h] |  |  |  |  |  | 0 | CHUDAKOV | 1 | 1 |  |  | Z | EUGENE C |  |  |  |  |  |  |  |  |  |  |  |  |  |  |  |  |
| 15211009EX |  | FY09 Travel (FWD Chambers) |  | 16d | 2008-12-01 A | 2008-12-22 A | 9-090M | 100% |  |  |  | TRAVEL | 306.8 |  | 100 | 100 | 0 | 306.8 | CHUDAKOV | 1 | 1 | D | 07-024 | E | EUGENE C | 08-058 |  | 11-006 |  |  |  |  |  |  |  |  |  |  |  | 11-026 | 12-054F |
| 123211060 |  | Re-Baseline Actuals Adjustment |  | 1d | 2013-08-30 A | 2013-08-30 A |  | 100% | 2013-09-03 | 2013-09-03 |  | PROCUREMENT>$50K 69 NO ESCALATION | 170,922.5 |  |  |  |  | 170922.5 |  |  |  |  |  |  |  |  |  |  |  | 0 | 170922.5 | 17092250 | 100 | ADJ |  |  |  |  |  |  |  |

| ID | WBS | Activity | Type | Duration | Start | Finish | Predecessors | Complete | Planned start | Planned finish | Constraint | Resources | Cost | Actual cost | Planned FinishUDF | MONTHLY EV COST | RESP - Responsibility | STRT%COMP for CM EVM | FNSH%COMP for CM EVM | CR 07-014 | EVMS Reporting Codes | CAM RESPONSIBLE | CR 09-012 | Remaining Material Cost Based on % Compl | Claimed Material Cost Based on % Complet | Initial Claimed Material Calc | Claimed Material Divider | Calculated Remaining Total Cost | CR 07-027 | LOE Divider | LOE Multiplier | HALL D Related Milestones | CR 07-024 | CR 08-058 | CR 11-006 | CR 11-026 | CR 12-054 | ReBaseline Actuals Adjustment | Milestone Level | Profile change | 12 GeV 1st level Critical Path | 12 GeV 5th level Critical Path |
| --- | --- | --- | --- | --- | --- | --- | --- | --- | --- | --- | --- | --- | --- | --- | --- | --- | --- | --- | --- | --- | --- | --- | --- | --- | --- | --- | --- | --- | --- | --- | --- | --- | --- | --- | --- | --- | --- | --- | --- | --- | --- | --- |
|  | 2 | **1.2.3.2.1.2 CENTRAL CHAMBERS** |  |  | 2007-09-04 | 2013-08-30 |  |  |  |  |  |  |  |  |  |  |  |  |  |  |  |  |  |  |  |  |  |  |  |  |  |  |  |  |  |  |  |  |  |  |  |  |
| 123212005 |  | Develop Preamp design (CENT CHAMB) |  | 19d | 2007-09-04 A | 2007-09-28 A | 9-070M | 100% |  |  |  |  |  |  | 2007-09-28 | 0 | CHUDAKOV | 1 | 1 | 07-014 | N/A | EUGENE C | 09-012 |  |  |  |  |  |  |  |  |  |  |  |  |  |  |  |  |  |  |  |
| 123212005A |  | Develop Preamp design (CENT CHAMB) |  | 227d | 2007-10-01 A | 2008-08-29 A | 123212005 | 100% |  |  |  | PROCUREMENT<$50K 60 NO ESCALATION FY08 | 51,600 |  | 2007-09-28 | 51600 | CHUDAKOV | 1 | 1 | 07-014 | N/A | EUGENE C | 09-012 | 0 | 51600 | 5160000 | 100 | 0 | 07-027 |  |  |  |  |  |  |  |  |  |  |  |  |  |
| 123212010 |  | Specify CDC Chamb Matrl's |  | 198d | 2008-01-14 A | 2008-10-22 A | 123212005A | 100% |  |  |  | CONTRB UNIV LBR [960 h] |  |  |  | 0 | CHUDAKOV | 1 | 1 |  | N/A | EUGENE C |  |  |  |  |  |  | 07-027 |  |  |  |  |  |  |  |  |  |  |  |  |  |
| 123212025 |  | Finalize CDC Cable Spec's, Connectors, Routing & Packing |  | 157d | 2008-01-14 A | 2008-08-25 A | 123212005A | 100% |  |  |  | MECH DES [1740 h] | 73,915.2 | 73,915.2 |  | 73915.2 | CHUDAKOV | 1 | 1 |  | N/A | EUGENE C |  |  |  |  |  | 0 | 07-027 |  |  |  |  |  |  |  |  |  |  |  |  |  |
| 123212030 |  | Comp CDC Final Drawings |  | 361d | 2008-01-14 A | 2009-06-23 A | 1152035 FS-200d, 123212015 FS-100d, 123212020, 123212008 FS-100d, 123212010, 1152030 FS-200d, 123212025 | 100% |  |  |  | MECH DES [1740 h] | 75,088.57 | 75,088.57 |  | 73915.2 | CHUDAKOV | 1 | 1 |  | N/A | EUGENE C |  |  |  |  |  | 0 | 07-027 |  |  |  |  |  |  |  |  |  |  |  |  |  |
| 123212020 |  | Dsgn CDC Gas Handling Sys |  | 164d | 2008-04-30 A | 2008-12-22 A | 123212005A | 100% |  |  |  | CONTRB UNIV LBR [1696 h] |  |  |  | 0 | CHUDAKOV | 1 | 1 |  | Z | EUGENE C |  |  |  |  |  |  | 07-027 |  |  |  |  |  |  |  |  |  |  |  |  |  |
| 123212008 |  | Preamp Dsgn |  | 341d | 2008-06-09 A | 2009-10-19 A | 123212005A | 100% |  |  |  | PROCUREMENT<$50K 60 | 32,804.1 |  |  | 32804.101 | CHUDAKOV | 1 | 1 |  | H | EUGENE C |  | 0 | 32804.1 | 3280410 | 100 | 0 | 07-027 |  |  |  |  |  |  |  |  |  |  |  |  |  |
| 123212015 |  | Detail CDC Final Procedure for Chamb Tube Mounting,/Wire Stringing,/Constrctn/Assy |  | 224d | 2008-07-28 A | 2009-06-22 A | 123212005A | 100% |  |  |  | CONTRB UNIV LBR [1480 h] |  |  |  | 0 | CHUDAKOV | 1 | 1 |  | Z | EUGENE C |  |  |  |  |  |  | 07-027 |  |  |  |  |  |  |  |  |  |  |  |  |  |
| 123212035 |  | Detail CDC Final Procedures for Component Quality Control & Acceptance |  | 226d | 2008-07-28 A | 2009-06-24 A | 123212030 | 100% |  |  |  | CONTRB UNIV LBR [1760 h] |  |  |  | 0 | CHUDAKOV | 1 | 1 |  | Z | EUGENE C |  |  |  |  |  |  | 07-027 |  |  |  |  |  |  |  |  |  |  |  |  |  |
| 15212009EX |  | FY09 Travel (CENT CHAMB) |  | 16d | 2008-12-01 A | 2008-12-22 A | 9-090M | 100% |  |  |  | TRAVEL | 306.8 |  |  | 306.8 | CHUDAKOV | 1 | 1 |  | E | EUGENE C |  |  |  |  |  | 0 |  | 100 | 100 | D | 07-024 | 08-058 | 11-006 | 11-026 | 12-054F |  |  |  |  |  |
| 123212040 |  | Re-Baseline Actuals Adjustment |  | 1d | 2013-08-30 A | 2013-08-30 A |  | 100% | 2013-09-03 | 2013-09-03 |  | PROCUREMENT>$50K 69 NO ESCALATION | 36,347.96 |  |  | 36347.96 |  |  |  |  |  |  |  | 0 | 36347.96 | 3634796 | 100 |  |  |  |  |  |  |  |  |  |  | ADJ |  |  |  |  |
|  | 3 | **1.2.3.2.1.3 START COUNTER** |  |  | 2006-10-02 | 2013-08-30 |  |  |  |  |  |  |  |  |  |  |  |  |  |  |  |  |  |  |  |  |  |  |  |  |  |  |  |  |  |  |  |  |  |  |  |  |
| 123213005LOE |  | Start counter design (START CNTR) |  | 247d | 2006-10-02 A | 2007-09-28 A | 9-070M | 100% |  |  |  |  |  |  | 2007-09-28 | 0 | CHUDAKOV | 1 | 1 | 07-014 | N/A | EUGENE C | 09-012 |  |  |  |  |  |  | 100 | 100 |  |  |  |  |  |  |  |  |  |  |  |
| 123213010 |  | Evaluate H-B Start Counter Use in H-D 08 |  | 207d | 2007-11-01 A | 2008-09-04 A | 123213005LOE | 100% |  |  |  | CONTRB UNIV LBR [704 h] |  |  |  | 0 | CHUDAKOV | 1 | 1 |  | N/A | EUGENE C |  |  |  |  |  |  |  |  |  |  |  |  |  |  |  |  |  |  |  |  |
| 123213015 |  | Re-Baseline Actuals Adjustment |  | 1d | 2013-08-30 A | 2013-08-30 A |  | 100% | 2013-09-03 | 2013-09-03 |  | PROCUREMENT>$50K 69 NO ESCALATION | 224.21 |  |  | 224.21 |  |  |  |  |  |  |  | 0 | 224.21 | 22421 | 100 |  |  |  |  |  |  |  |  |  |  | ADJ |  |  |  |  |
|  | 2 | **1.2.3.2.2 CALORIMETRY** |  |  | 2006-10-02 | 2013-08-30 |  |  |  |  |  |  |  |  |  |  |  |  |  |  |  |  |  |  |  |  |  |  |  |  |  |  |  |  |  |  |  |  |  |  |  |  |
| 12322017 |  | Final Dsgn & Safty Assessmnt of Calorimeters |  | 28d | 2008-09-24 A | 2008-10-31 A | 123222020, 123221804bLOE, 123223010, 123222025, 123223020, 123221025, 123223015, 123222030 | 100% |  |  |  |  |  |  |  | 0 | CHUDAKOV | 1 | 1 |  | Z | EUGENE C |  |  |  |  |  |  | 07-027 |  |  |  |  |  |  |  |  |  |  |  |  |  |
| 12322018M |  | Calorimeter Dsgn Rquirmnts Finalized++ | milestone | 0d | 2008-10-31 A | 2008-10-31 A | 12322017 | 100% | 2009-02-25 | 2009-02-25 |  |  |  |  |  | 0 | CHUDAKOV | 1 | 1 |  | M | EUGENE C |  |  |  |  |  |  | 07-027 |  |  | D |  |  |  |  |  |  | 6 | C |  |  |
|  | 1 | **1.2.3.2.2.1 BARREL CALORIMETER** |  |  | 2006-10-02 | 2013-08-30 |  |  |  |  |  |  |  |  |  |  |  |  |  |  |  |  |  |  |  |  |  |  |  |  |  |  |  |  |  |  |  |  |  |  |  |  |
| 123221007LOE |  | FY07 Hall D project administration (BCAL) |  | 79d | 2006-10-02 A | 2007-02-01 A | 9-070M | 100% |  |  |  | SCIENTIST [122.8 h] | 7,882.53 | 7,882.53 | 2007-09-28 | 7882.527843 | CHUDAKOV | 1 | 1 | 07-014 | N/A | EUGENE C | 09-012 |  |  |  |  | 0 | 07-027 | 100 | 100 |  |  |  |  |  |  |  |  |  |  |  |
| 123221002 |  | Develop BCAL design (BCAL) |  | 58d | 2006-11-01 A | 2007-02-01 A | 9-070M | 100% |  |  |  | CONTRB UNIV LBR [755.2 h] |  |  | 2007-09-28 | 0 | CHUDAKOV | 1 | 1 | 07-014 | N/A | EUGENE C | 09-012 |  |  |  |  |  |  |  |  |  |  |  |  |  |  |  |  |  | 1 | 5 |
| 123221000 |  | Assessment of SiPM progress toward use with BCAL |  | 98d | 2006-12-01 A | 2007-04-27 A | 9-070M FS+58d | 100% |  |  |  |  |  |  | 2007-01-30 | 0 | CHUDAKOV | 1 | 1 | 07-014 | N/A | EUGENE C |  |  |  |  |  |  |  |  |  |  |  |  |  |  |  |  |  |  |  |  |
| 123221007ALOE |  | FY07 Hall D project administration (BCAL) |  | 168d | 2007-02-01 A | 2007-09-28 A | 123221007LOE | 100% |  |  | start on or after 2007-02-02 | SCIENTIST [337.6 h] | 21,100.16 | 21,100.16 | 2007-09-28 | 21096.742665 | CHUDAKOV | 1 | 1 | 07-014 | N/A | EUGENE C | 09-012 |  |  |  |  | 0 |  | 100 | 100 |  |  |  |  |  |  |  |  |  |  |  |
| 123221002A |  | Develop BCAL design (BCAL) |  | 167d | 2007-02-02 A | 2007-09-28 A | 123221002 | 100% |  |  |  | MECH ENG [520 h]; MECH DES [1020 h] | 75,578.56 | 75,578.56 | 2007-09-28 | 75578.559354 | CHUDAKOV | 1 | 1 | 07-014 | N/A | EUGENE C | 09-012 |  |  |  |  | 0 | 07-027 |  |  |  |  |  |  |  |  |  |  |  | 1 | 5 |
| 123221004 |  | FY07 BCAL postdoc for design (BCAL) |  | 259d | 2007-04-16 A | 2008-04-30 A | 123221000M, 9-070M FS+130d | 100% |  |  |  | PD UNIV STAFF [1200 h] | 59,142.59 | 59,142.59 | 2007-09-28 | 58742.787692 | CHUDAKOV | 1 | 1 | 07-014 | N/A | EUGENE C |  |  |  |  |  | 0 |  |  |  |  |  |  |  |  |  |  |  |  |  |  |
| 123221000M |  | Decision on readout for BCAL | milestone | 0d | 2007-05-31 A | 2007-05-31 A | 123221000 FS+21d | 100% | 2007-03-01 | 2007-03-01 |  |  |  |  | 2007-03-01 | 0 | CHUDAKOV | 1 | 1 | 07-014 | N/A | EUGENE C |  |  |  |  |  |  |  |  |  |  |  |  |  |  |  |  | 9 |  |  |  |
| 123221004LOE |  | FY07 BCAL postdoc for design (BCAL) |  | 1d | 2007-09-04 A | 2007-09-04 A | 9-070M | 100% |  |  |  |  |  |  | 2007-09-28 | 0 | CHUDAKOV | 1 | 1 | 07-014 | N/A | EUGENE C | 09-012 |  |  |  |  |  |  | 100 | 100 |  |  |  |  |  |  |  |  |  |  |  |
| 123221908LOE |  | FY08 H-D Proj Admin (BCAL) |  | 101d | 2007-10-01 A | 2008-03-04 A | 123221007LOE, 123221007ALOE | 100% |  |  |  | SCIENTIST [440 h] | 27,398.8 | 27,398.8 |  | 27467.487371 | CHUDAKOV | 1 | 1 |  | N/A | EUGENE C |  |  |  |  |  | 0 | 07-027 | 100 | 100 |  |  |  |  |  |  |  |  |  |  |  |
| 123221804bLOE |  | FY08 BCAL postdoc for Dsgn (BCAL) |  | 10d | 2007-10-02 A | 2007-10-15 A | 1152010A, 9-080M, 123221004LOE, 1152015LOEA, 123221004 | 100% |  |  |  | PD UNIV STAFF [60 h] | 2,973.6 | 2,973.6 |  | 2973.6 | CHUDAKOV | 1 | 1 |  | N/A | EUGENE C |  |  |  |  |  | 0 |  | 100 | 100 |  |  |  |  |  |  |  |  |  |  |  |
| 123221020 |  | Drawings of Supprt in Solenoid (BCAL) |  | 403d | 2007-11-01 A | 2009-06-22 A | 123221002A | 100% |  |  |  | PD UNIV STAFF [440 h]; CONTRB UNIV LBR [1196 h] | 22,113.46 | 22,113.46 |  | 21806.4 | CHUDAKOV | 1 | 1 |  | N/A | EUGENE C |  |  |  |  |  | 0 | 07-027 |  |  |  |  |  |  |  |  |  |  |  | 1 | 5 |
| 123221025 |  | Assy Drawings (BCAL) |  | 316d | 2008-01-14 A | 2009-04-20 A | 123221020 FS-60d, 1152040 FS-40d | 100% |  |  |  | MECH ENG [648 h]; PROCUREMENT<$50K 60; CONTRB UNIV LBR [1240 h]; PD UNIV STAFF [364 h] | 108,098.36 | 58,897.37 |  | 107313.152 | CHUDAKOV | 1 | 1 |  | N/A | EUGENE C |  | 0 | 49200.99 | 4920099 | 100 | 0 | 07-027 |  |  |  | 07-024 |  |  |  |  |  |  |  | 1 | 5 |
| 15221009EX |  | FY09 Travel (BarCal) |  | 16d | 2008-12-01 A | 2008-12-22 A | 123221908LOE, 9-090M | 100% |  |  |  | TRAVEL | 1,756.43 |  |  | 1756.43 | CHUDAKOV | 1 | 1 |  | E | EUGENE C |  |  |  |  |  | 0 |  | 100 | 100 | D | 07-024 | 08-058 | 11-006 | 11-026 |  |  |  |  |  |  |
| 123221030 |  | Re-Baseline Actuals Adjustment |  | 1d | 2013-08-30 A | 2013-08-30 A |  | 100% | 2013-09-03 | 2013-09-03 |  | PROCUREMENT>$50K 69 NO ESCALATION | 133,589.16 |  |  | 133589.16 |  |  |  |  |  |  |  | 0 | 133589.16 | 13358916 | 100 |  |  |  |  |  |  |  |  |  |  | ADJ |  |  |  |  |

Notes:
- 123212005: TEST of New Cat: Move 30K to ACD ask Will
- 123212005A: TEST of New Cat: Move 30K to ACD ask Will
- 123221025: Explanation: Removed 15221010 as a successor 30April2009.

| ID | WBS | Activity | Type | Duration | Start | Finish | Predecessors | Complete | Planned start | Planned finish | Resources | Cost | Actual cost | Planned FinishUDF | MONTHLY EV COST | RESP - Responsibility | STRT%COMP for CM EVM | FNSH%COMP for CM EVM | CR 07-014 | EVMS Reporting Codes | CAM RESPONSIBLE | CR 09-012 | Remaining Material Cost Based on % Compl | Claimed Material Cost Based on % Complet | Initial Claimed Material Calc | Claimed Material Divider | Calculated Remaining Total Cost | CR 07-024 | LOE Divider | LOE Multiplier | HALL D Related Milestones | CR 08-058 | CR 11-006 | CR 11-026 | CR 12-054 | ReBaseline Actuals Adjustment | CR 07-027 | Milestone Level |
| --- | --- | --- | --- | --- | --- | --- | --- | --- | --- | --- | --- | --- | --- | --- | --- | --- | --- | --- | --- | --- | --- | --- | --- | --- | --- | --- | --- | --- | --- | --- | --- | --- | --- | --- | --- | --- | --- | --- |
|  | 2 | **1.2.3.2.2.2 FORWARD CALORIMETER** |  |  | 2007-03-01 | 2013-08-30 |  |  |  |  |  |  |  |  |  |  |  |  |  |  |  |  |  |  |  |  |  |  |  |  |  |  |  |  |  |  |  |  |
| 123222005 |  | Develop FCAL modifications for use in Hall D (FCAL) |  | 65d | 2007-03-01 A | 2007-05-31 A | 9-070M | 100% |  |  |  |  |  | 2007-09-28 | 0 | CHUDAKOV | 1 | 1 | 07-014 | N/A | EUGENE C | 09-012 |  |  |  |  |  |  |  |  |  |  |  |  |  |  |  |  |
| 123222010 |  | Drawings of Glass Supprt to circular geometry (FCAL) |  | 447d | 2007-11-01 A | 2009-08-24 A | 1152025A, 123222005 | 100% |  |  | PROCUREMENT>$50K 69; CONTRB UNIV LBR [480 h]; MECH ENG [880 h] | 109,908.97 | 55,280.18 |  | 109047.986 | CHUDAKOV | 1 | 1 |  | N/A | EUGENE C |  | 0 | 54628.79 | 5462879 | 100 | 0 | 07-024 |  |  |  |  |  |  |  |  |  |  |
| 123222015 |  | Drawings of Cellular Wall (FCAL) |  | 447d | 2007-11-01 A | 2009-08-24 A | 123222005 | 100% |  |  | PROCUREMENT<$50K 60 | 54,628.79 |  |  | 54628.79 | CHUDAKOV | 1 | 1 |  | N/A | EUGENE C |  | 0 | 54628.79 | 5462879 | 100 | 0 |  |  |  |  |  |  |  |  |  |  |  |
| 123222025 |  | Drawings for attaching PMTs to Glass (FCAL) |  | 372d | 2008-02-29 A | 2009-08-24 A | 123222005 | 100% |  |  | CONTRB UNIV LBR [880 h] |  |  |  | 0 | CHUDAKOV | 1 | 1 |  | N/A | EUGENE C |  |  |  |  |  |  |  |  |  |  |  |  |  |  |  |  |  |
| 123222030 |  | Drawings for Light Guides (FCAL) |  | 372d | 2008-02-29 A | 2009-08-24 A | 123222005 | 100% |  |  | PD UNIV STUDNT [880 h] | 8,438.35 | 8,438.35 |  | 8280.8 | CHUDAKOV | 1 | 1 |  | N/A | EUGENE C |  |  |  |  |  | 0 |  |  |  |  |  |  |  |  |  |  |  |
| 123222020 |  | Assy Plans for stacking Glass (FCAL) |  | 226d | 2008-09-25 A | 2009-08-24 A | 123222010 FS-125d, 123222005 FS-125d, 123222015 FS-125d | 100% |  |  | PD UNIV STUDNT [856.12 h]; CONTRB UNIV LBR [359.88 h] | 8,308.36 | 8,308.36 |  | 8056.073975 | CHUDAKOV | 1 | 1 |  | H | EUGENE C |  |  |  |  |  | 0 |  |  |  |  |  |  |  |  |  |  |  |
| 15222009EX |  | FY09 Travel (FWD CAL) |  | 16d | 2008-12-01 A | 2008-12-22 A | 9-090M | 100% |  |  | TRAVEL | 201.78 |  |  | 201.78 | CHUDAKOV | 1 | 1 |  | E | EUGENE C |  |  |  |  |  | 0 | 07-024 | 100 | 100 | D | 08-058 | 11-006 | 11-026 | 12-054F |  |  |  |
| 123222035 |  | Re-Baseline Actuals Adjustment |  | 1d | 2013-08-30 A | 2013-08-30 A |  | 100% | 2013-09-03 | 2013-09-03 | PROCUREMENT>$50K 69 NO ESCALATION | -1,142.37 |  |  |  |  |  |  |  |  |  |  |  |  |  | 100 |  |  |  |  |  |  |  |  |  | ADJ |  |  |
|  | 3 | **1.2.3.2.2.3 UPSTREAM PHOTON VETO** |  |  | 2006-10-02 | 2008-03-21 |  |  |  |  |  |  |  |  |  |  |  |  |  |  |  |  |  |  |  |  |  |  |  |  |  |  |  |  |  |  |  |  |
| 123223005LOE |  | Develop Upstream Photon Veto Design (CAL TOF) |  | 80d | 2006-10-02 A | 2007-02-01 A | 9-070M | 100% |  |  | CONTRB UNIV LBR [44.8 h] |  |  | 2007-09-28 | 0 | CHUDAKOV | 1 | 1 | 07-014 | N/A | EUGENE C |  |  |  |  |  |  |  | 100 | 100 |  |  |  |  |  |  |  |  |
| 123223005ALOE |  | Develop Upstream Photon Veto Design (CAL TOF) |  | 83d | 2007-02-02 A | 2007-05-31 A | 123223005LOE | 100% |  |  |  |  |  | 2007-09-28 | 0 | CHUDAKOV | 1 | 1 | 07-014 | N/A | EUGENE C | 09-012 |  |  |  |  |  |  | 100 | 100 |  |  |  |  |  |  |  |  |
| 123223010 |  | Drawings for UPV Frame (CAL TOF) |  | 5d | 2008-03-03 A | 2008-03-07 A | 123223005ALOE, 1152020 | 100% |  |  | CONTRB UNIV LBR [40 h] |  |  |  | 0 | CHUDAKOV | 1 | 1 |  | N/A | EUGENE C |  |  |  |  |  |  |  |  |  |  |  |  |  |  |  |  |  |
| 123223015 |  | Drawings for individual Compnts (CAL TOF) |  | 5d | 2008-03-10 A | 2008-03-14 A | 123223005ALOE | 100% |  |  | CONTRB UNIV LBR [40 h] |  |  |  | 0 | CHUDAKOV | 1 | 1 |  | N/A | EUGENE C |  |  |  |  |  |  |  |  |  |  |  |  |  |  |  |  |  |
| 123223020 |  | Dsgn Supprt Frame & method for maintenance (CAL TOF) |  | 5d | 2008-03-17 A | 2008-03-21 A | 123223015, 123223010 | 100% |  |  | CONTRB UNIV LBR [80 h] |  |  |  | 0 | CHUDAKOV | 1 | 1 |  | N/A | EUGENE C |  |  |  |  |  |  |  |  |  |  |  |  |  |  |  |  |  |
|  | 3 | **1.2.3.2.3 PARTICLE ID** |  |  | 2006-10-02 | 2013-08-30 |  |  |  |  |  |  |  |  |  |  |  |  |  |  |  |  |  |  |  |  |  |  |  |  |  |  |  |  |  |  |  |  |
| 12323039 |  | Final Dsgn & Safty Assessmnt of Particle ID |  | 74d | 2009-01-05 A | 2009-04-20 A | 123232035, 123232010, 123232015, 123232020, 123231030 FS-250d, 123232025, 123232030 | 100% |  |  |  |  |  |  | 0 | CHUDAKOV | 1 | 1 |  | Z | EUGENE C |  |  |  |  |  |  |  |  |  |  |  |  |  |  |  | 07-027 |  |
| 12323040M |  | Particle ID Dsgn Rquirmnts Finalized++ | milestone | 0d | 2009-04-20 A | 2009-04-20 A | 12323039 | 100% | 2009-06-02 | 2009-06-02 |  |  |  |  | 0 | CHUDAKOV | 1 | 1 |  | M | EUGENE C |  |  |  |  |  |  |  |  |  | D |  |  |  |  |  | 07-027 | 6 |
|  | 1 | **1.2.3.2.3.1 TIME OF FLIGHT** |  |  | 2006-10-02 | 2009-07-27 |  |  |  |  |  |  |  |  |  |  |  |  |  |  |  |  |  |  |  |  |  |  |  |  |  |  |  |  |  |  |  |  |
| 123231005LOE |  | Develop TOF integration (PART ID TOF) |  | 80d | 2006-10-02 A | 2007-02-01 A | 9-070M | 100% |  |  | CONTRB UNIV LBR [552 h] |  |  | 2007-09-28 | 0 | CHUDAKOV | 1 | 1 | 07-014 | N/A | EUGENE C |  |  |  |  |  |  |  | 100 | 100 |  |  |  |  |  |  |  |  |
| 123231005ALOE |  | Develop TOF integration (PART ID TOF) |  | 83d | 2007-02-02 A | 2007-05-31 A | 123231005LOE | 100% |  |  |  |  |  | 2007-09-28 | 0 | CHUDAKOV | 1 | 1 | 07-014 | N/A | EUGENE C |  |  |  |  |  |  |  | 100 | 100 |  |  |  |  |  |  |  |  |
| 123231010 |  | Drawings of Scintillator Counters (PART ID TOF) |  | 307d | 2008-03-31 A | 2009-06-22 A | 123231005ALOE FS+260d | 100% |  |  | CONTRB UNIV LBR [360 h] |  |  |  | 0 | CHUDAKOV | 1 | 1 |  | Z | EUGENE C |  |  |  |  |  |  |  |  |  |  |  |  |  |  |  |  |  |
| 123231015 |  | Drawings of PMT Housing Assy (PART ID TOF) |  | 309d | 2008-03-31 A | 2009-06-24 A | 123231010 | 100% |  |  | CONTRB UNIV LBR [360 h] |  |  |  | 0 | CHUDAKOV | 1 | 1 |  | Z | EUGENE C |  |  |  |  |  |  |  |  |  |  |  |  |  |  |  |  |  |
| 123231020 |  | Dsgn Voltage Divider for PMT (PART ID TOF) |  | 331d | 2008-03-31 A | 2009-07-27 A | 123231015 | 100% |  |  | CONTRB UNIV LBR [360 h] |  |  |  | 0 | CHUDAKOV | 1 | 1 |  | Z | EUGENE C |  |  |  |  |  |  |  |  |  |  |  |  |  |  |  |  |  |
| 123231025 |  | Dsgn Signal Splitting Between ADC & Discriminator/TDC (PART ID TOF) |  | 330d | 2008-03-31 A | 2009-07-27 A | 123231020 | 100% | 2008-03-31 | 2009-07-24 | CONTRB UNIV LBR [360 h] |  |  |  | 0 | CHUDAKOV | 1 | 1 |  | Z | EUGENE C |  |  |  |  |  |  |  |  |  |  |  |  |  |  |  |  |  |
| 123231030 |  | Dsgn Mounting Frame for Counters (PART ID TOF) |  | 312d | 2008-03-31 A | 2009-06-29 A | 123231025 | 100% |  |  | CONTRB UNIV LBR [520 h] |  |  |  | 0 | CHUDAKOV | 1 | 1 |  | Z | EUGENE C |  |  |  |  |  |  |  |  |  |  |  |  |  |  |  |  |  |

Notes:
- 123222020: Explanation: 29May2009 Added -25 w of lag. Increased Remaining Duration.

| ID | WBS | Activity | Type | Duration | Start | Finish | Predecessors | Complete | Planned start | Planned finish | Resources | Cost | Actual cost | Planned FinishUDF | Calculated Remaining Total Cost | MONTHLY EV COST | RESP - Responsibility | STRT%COMP for CM EVM | FNSH%COMP for CM EVM | CR 07-014 | CR 07-027 | EVMS Reporting Codes | CAM RESPONSIBLE | CR 09-012 | CR 07-024 | Claimed Material Divider | ReBaseline Actuals Adjustment | Milestone Level | HALL D Related Milestones | Remaining Material Cost Based on % Compl | Claimed Material Cost Based on % Complet | Initial Claimed Material Calc | Inter Project Link (IPL) | LOE Divider | LOE Multiplier | ACT BRIDGING FY SPLIT | EXPNS ACT BRIDGING FY SPLIT | CR 09-001 |
| --- | --- | --- | --- | --- | --- | --- | --- | --- | --- | --- | --- | --- | --- | --- | --- | --- | --- | --- | --- | --- | --- | --- | --- | --- | --- | --- | --- | --- | --- | --- | --- | --- | --- | --- | --- | --- | --- | --- |
|  | 2 | **1.2.3.2.3.2 CERENKOV COUNTER** |  |  | 2007-03-01 | 2013-08-30 |  |  |  |  |  |  |  |  |  |  |  |  |  |  |  |  |  |  |  |  |  |  |  |  |  |  |  |  |  |  |  |  |
| 123232005A |  | Develop CER design (CERENKOV CNTR) |  | 149d | 2007-03-01 A | 2007-09-28 A | 123232005 | 100% |  |  | SCIENTIST [332 h]; VISTNG USERS [600 h]; PD UNIV STUDNT [416 h] | 34,788.03 | 34,788.03 | 2007-09-28 | 0 | 34894.553276 | CHUDAKOV | 1 | 1 | 07-014 | 07-027 | N/A | EUGENE C | 09-012 |  |  |  |  |  |  |  |  |  |  |  |  |  |  |
| 123232005 |  | Develop CER design (CERENKOV CNTR) |  | 1d | 2008-01-03 A | 2008-01-03 A | 9-070M | 100% |  |  |  |  |  | 2007-09-28 |  | 0 | CHUDAKOV | 1 | 1 | 07-014 |  | N/A | EUGENE C | 09-012 |  |  |  |  |  |  |  |  |  |  |  |  |  |  |
| 123232010 |  | Comp Spec's for Mirrors (CERENKOV CNTR) |  | 1d | 2008-01-03 A | 2008-01-03 A | 9-090M FS+120d, 1152025A, 123232005A | 100% |  |  |  |  |  |  |  | 0 | CHUDAKOV | 1 | 1 |  | 07-027 | N/A | EUGENE C | 09-012 | 07-024 |  |  |  |  |  |  |  |  |  |  |  |  |  |
| 123232015 |  | Comp Drawings for Mirrors & Fab (CERENKOV CNTR) |  | 1d | 2008-01-03 A | 2008-01-03 A | 9-090M FS+60d, 123232005A | 100% |  |  |  |  |  |  |  | 0 | CHUDAKOV | 1 | 1 |  | 07-027 | N/A | EUGENE C | 09-012 | 07-024 |  |  |  |  |  |  |  |  |  |  |  |  |  |
| 123232020 |  | Drawings for PMT Assy (CERENKOV CNTR) |  | 1d | 2008-01-03 A | 2008-01-03 A | 123232005A FS+180d, 9-090M FS+120d | 100% |  |  |  |  |  |  |  | 0 | CHUDAKOV | 1 | 1 |  | 07-027 | N/A | EUGENE C | 09-012 | 07-024 |  |  |  |  |  |  |  |  |  |  |  |  |  |
| 123232025 |  | Develop Matrl Spec's for Gas Windows (CERENKOV CNTR) |  | 1d | 2008-01-03 A | 2008-01-03 A | 9-090M FS+60d, 123232005A | 100% |  |  |  |  |  |  |  | 0 | CHUDAKOV | 1 | 1 |  | 07-027 | N/A | EUGENE C | 09-012 | 07-024 |  |  |  |  |  |  |  |  |  |  |  |  |  |
| 123232030 |  | Dsgn Supprt Frame for Cerenkov Detector (CERENKOV CNTR) |  | 1d | 2008-01-03 A | 2008-01-03 A | 9-090M FS+60d, 123232005A | 100% |  |  |  |  |  |  |  | 0 | CHUDAKOV | 1 | 1 |  | 07-027 | N/A | EUGENE C | 09-012 | 07-024 |  |  |  |  |  |  |  |  |  |  |  |  |  |
| 123232035 |  | Dsgn Alignment Procedure for Mirrors (CERENKOV CNTR) |  | 1d | 2008-01-03 A | 2008-01-03 A | 123232005A, 9-090M FS+60d | 100% |  |  |  |  |  |  |  | 0 | CHUDAKOV | 1 | 1 |  | 07-027 | N/A | EUGENE C | 09-012 | 07-024 |  |  |  |  |  |  |  |  |  |  |  |  |  |
| 123232040 |  | Re-Baseline Actuals Adjustment |  | 1d | 2013-08-30 A | 2013-08-30 A |  | 100% | 2013-09-03 | 2013-09-03 | PROCUREMENT>$50K 69 NO ESCALATION | -12,101.94 |  |  |  |  |  |  |  |  |  |  |  |  |  | 100 | ADJ |  |  |  |  |  |  |  |  |  |  |  |
|  | 3 | **1.2.3.3 COMPUTING** |  |  | 2006-10-02 | 2013-08-30 |  |  |  |  |  |  |  |  |  |  |  |  |  |  |  |  |  |  |  |  |  |  |  |  |  |  |  |  |  |  |  |  |
| 1233039 |  | Final Dsgn & Safty Assessmnt of Computing |  | 122d | 2009-01-05 A | 2009-06-26 A | 12331010, 12332025a FS-250d, 12333020, 12333015a FS-250d, 12332015 FS-250d | 100% |  |  |  |  |  |  |  | 0 | CHUDAKOV | 1 | 1 |  | 07-027 | Z | EUGENE C |  |  |  |  |  |  |  |  |  |  |  |  |  |  |  |
| 1233040M |  | Computing Dsgn Rquirmnts Finalized+ | milestone | 0d | 2009-06-26 A | 2009-06-26 A | 1233039 | 100% | 2009-08-26 | 2009-08-26 |  |  |  |  |  | 0 | CHUDAKOV | 1 | 1 |  | 07-027 | M | EUGENE C |  |  |  |  | 6 | D |  |  |  |  |  |  |  |  |  |
|  | 1 | **1.2.3.3.1 DAQ** |  |  | 2007-01-16 | 2013-08-30 |  |  |  |  |  |  |  |  |  |  |  |  |  |  |  |  |  |  |  |  |  |  |  |  |  |  |  |  |  |  |  |  |
| 12331005 |  | Procure architechture and high speed links (DAQ) |  | 180d | 2007-01-16 A | 2007-09-28 A | 9-070M | 100% |  |  | PROCUREMENT<$50K 60 | 20,640 |  | 2007-09-28 | 0 | 20640 | CHUDAKOV | 1 | 1 | 07-014 | 07-027 | N/A | EUGENE C |  |  | 100 |  |  |  | 0 | 20640 | 2064000 |  |  |  |  |  |  |
| 12331010 |  | Proto parallel Event builder (DAQ) (IPL) |  | 194d | 2008-01-15 A | 2008-10-17 A | 12331005 FS+110d | 100% |  |  | PROCUREMENT<$50K 60 | 43,659.69 |  |  | 0 | 43659.689 | CHUDAKOV | 1 | 1 |  | 07-027 | N/A | EUGENE C |  |  | 100 |  |  |  | 0 | 43659.69 | 4365969 | IPL |  |  |  |  |  |
| 12331015 |  | Re-Baseline Actuals Adjustment |  | 1d | 2013-08-30 A | 2013-08-30 A |  | 100% | 2013-09-03 | 2013-09-03 | PROCUREMENT>$50K 69 NO ESCALATION | 13,201.48 |  |  |  | 13201.48 |  |  |  |  |  |  |  |  |  | 100 | ADJ |  |  | 0 | 13201.48 | 1320148 |  |  |  |  |  |  |
|  | 2 | **1.2.3.3.2 ONLINE COMPUTING** |  |  | 2006-10-02 | 2013-08-30 |  |  |  |  |  |  |  |  |  |  |  |  |  |  |  |  |  |  |  |  |  |  |  |  |  |  |  |  |  |  |  |  |
| 12332005LOE |  | Conduct planning for online system (ONLINE COMP) |  | 80d | 2006-10-02 A | 2007-02-01 A | 9-070M | 100% |  |  | CONTRB UNIV LBR [101.2 h] |  |  | 2007-09-28 |  | 0 | CHUDAKOV | 1 | 1 | 07-014 |  | N/A | EUGENE C |  |  |  |  |  |  |  |  |  |  | 100 | 100 |  |  |  |
| 12332005ALOE |  | Conduct planning for online system (ONLINE COMP) |  | 83d | 2007-02-02 A | 2007-05-31 A | 12332005LOE | 100% |  |  |  |  |  | 2007-09-28 |  | 0 | CHUDAKOV | 1 | 1 | 07-014 |  | N/A | EUGENE C | 09-012 |  |  |  |  |  |  |  |  |  | 100 | 100 |  |  |  |
| 12332020 |  | Dsgn Experiment Controls Sys (ONLINE COMP) |  | 283d | 2008-02-01 A | 2009-03-23 A | 12332005ALOE, 9-080M FS+60d | 100% |  |  | SCIENTIST [920 h] | 58,025.9 | 58,025.9 |  | 0 | 57288.4 | CHUDAKOV | 1 | 1 |  | 07-027 | N/A | EUGENE C |  | 07-024 |  |  |  |  |  |  |  |  |  |  |  |  |  |
| 12332010 |  | Dsgn Monitoring Sys (ONLINE COMP) |  | 242d | 2008-04-01 A | 2009-03-23 A | 12332005ALOE, 9-080M FS+120d | 100% |  |  | SCIENTIST [80 h] | 5,056.6 | 5,056.6 |  | 0 | 4981.6 | CHUDAKOV | 1 | 1 |  | 07-027 | H | EUGENE C |  | 07-024 |  |  |  |  |  |  |  |  |  |  |  |  |  |
| 12332015 |  | Dsgn Alarm Sys (ONLINE COMP) |  | 242d | 2008-04-01 A | 2009-03-23 A | 12332010 | 100% |  |  | PROCUREMENT<$50K 60; SCIENTIST [408 h] | 38,883.44 | 25,788.63 |  | 0 | 38500.971 | CHUDAKOV | 1 | 1 |  |  | H | EUGENE C |  | 07-024 | 100 |  |  |  | 0 | 13094.81 | 1309481 |  |  |  |  |  |  |
| 12332025 |  | FY08 Dsgn Event Display (ONLINE COMP) |  | 139d | 2008-11-03 A | 2009-05-29 A | 12332020 FS-200d | 100% |  |  | CONTRB UNIV LBR [49.85 h]; SCIENTIST [105.23 h] | 6,762.08 | 6,762.08 |  | 0 | 6552.6721 | CHUDAKOV | 1 | 1 |  |  | H | EUGENE C |  | 07-024 |  |  |  | D |  |  |  |  |  |  | FY08-09 | EXP0809 | 09-001 |
| 12332025a |  | FY09 Dsgn Event Display (ONLINE COMP) |  | 120d | 2008-12-02 A | 2009-05-29 A | 12332025 FS-200d | 100% |  |  | SCIENTIST [654.77 h]; CONTRB UNIV LBR [310.15 h] | 42,075.52 | 42,075.52 |  | 0 | 42075.5202 | CHUDAKOV | 1 | 1 |  |  | H | EUGENE C |  | 07-024 |  |  |  | D |  |  |  |  |  |  | FY08-09 | EXP0809 | 09-001 |
| 12332030 |  | Re-Baseline Actuals Adjustment |  | 1d | 2013-08-30 A | 2013-08-30 A |  | 100% | 2013-09-03 | 2013-09-03 | PROCUREMENT>$50K 69 NO ESCALATION | -24,281.09 |  |  |  |  |  |  |  |  |  |  |  |  |  | 100 | ADJ |  |  |  |  |  |  |  |  |  |  |  |

| ID | WBS | Activity | Type | Duration | Start | Finish | Predecessors | Complete | Planned start | Planned finish | Resources | Cost | Actual cost | Planned FinishUDF | LOE Divider | LOE Multiplier | MONTHLY EV COST | RESP - Responsibility | STRT%COMP for CM EVM | FNSH%COMP for CM EVM | CR 07-014 | EVMS Reporting Codes | CAM RESPONSIBLE | Calculated Remaining Total Cost | CR 07-027 | ACT BRIDGING FY SPLIT | HALL D Related Milestones | EXPNS ACT BRIDGING FY SPLIT | CR 09-001 | Remaining Material Cost Based on % Compl | Claimed Material Cost Based on % Complet | Initial Claimed Material Calc | Claimed Material Divider | ReBaseline Actuals Adjustment | CR 07-002 | CR 09-012 | Inter Project Link (IPL) | CR 08-016 | CR 07-024 | CR 08-058 | CR 11-006 | CR 11-026 | CR 11-029 | Milestone Level |
| --- | --- | --- | --- | --- | --- | --- | --- | --- | --- | --- | --- | --- | --- | --- | --- | --- | --- | --- | --- | --- | --- | --- | --- | --- | --- | --- | --- | --- | --- | --- | --- | --- | --- | --- | --- | --- | --- | --- | --- | --- | --- | --- | --- | --- |
|  | 3 | **1.2.3.3.3 OFFLINE COMPUTING** |  |  | 2006-10-02 | 2013-08-30 |  |  |  |  |  |  |  |  |  |  |  |  |  |  |  |  |  |  |  |  |  |  |  |  |  |  |  |  |  |  |  |  |  |  |  |  |  |  |
| 12333005LOE |  | Conduct planning for offline computing (OFFLINE COMP) |  | 80d | 2006-10-02 A | 2007-02-01 A | 9-070M | 100% |  |  | CONTRB UNIV LBR [202.8 h] |  |  | 2007-09-28 | 100 | 100 | 0 | CHUDAKOV | 1 | 1 | 07-014 | N/A | EUGENE C |  |  |  |  |  |  |  |  |  |  |  |  |  |  |  |  |  |  |  |  |  |
| 12333005ALOE |  | Conduct planning for offline computing (OFFLINE COMP) |  | 83d | 2007-02-02 A | 2007-05-31 A | 12333005LOE | 100% |  |  |  |  |  | 2007-09-28 | 100 | 100 | 0 | CHUDAKOV | 1 | 1 | 07-014 | N/A | EUGENE C |  |  |  |  |  |  |  |  |  |  |  |  |  |  |  |  |  |  |  |  |  |
| 12333010 |  | Dsgn Reconstruction Framework (OFFLINE COMP) |  | 227d | 2007-10-01 A | 2008-08-29 A | 12333005ALOE | 100% |  |  | CONTRB UNIV LBR [2204 h]; SCIENTIST [1300 h] | 80,951 | 80,951 |  |  |  | 80951 | CHUDAKOV | 1 | 1 |  | N/A | EUGENE C | 0 | 07-027 |  |  |  |  |  |  |  |  |  |  |  |  |  |  |  |  |  |  |  |
| 12333020 |  | Dsgn Interface Between Analysis Framework & Simulation (OFFLINE COMP) |  | 104d | 2008-01-03 A | 2008-05-30 A | 12333010 FS+71d | 100% |  |  | CONTRB UNIV LBR [1000 h] |  |  |  |  |  | 0 | CHUDAKOV | 1 | 1 |  | N/A | EUGENE C |  | 07-027 | FY08-09 |  |  |  |  |  |  |  |  |  |  |  |  |  |  |  |  |  |  |
| 12333015 |  | FY08 Dsgn Calibration Databases (OFFLINE COMP) |  | 162d | 2008-10-01 A | 2009-05-29 A | 12333010 FS+71d | 100% |  |  | CONTRB UNIV LBR [361.54 h]; SCIENTIST [477.23 h] | 30,666.8 | 30,666.8 |  |  |  | 29717.1121 | CHUDAKOV | 1 | 1 |  | H | EUGENE C | 0 | 07-027 | FY08-09 | D | EXP0809 | 09-001 |  |  |  |  |  |  |  |  |  |  |  |  |  |  |  |
| 12333015a |  | FY09 Dsgn Calibration Databases (OFFLINE COMP) |  | 120d | 2008-12-02 A | 2009-05-29 A | 12333015 FS-250d | 100% |  |  | SCIENTIST [842.77 h]; CONTRB UNIV LBR [638.46 h] | 54,156.4 | 54,156.4 |  |  |  | 54156.4002 | CHUDAKOV | 1 | 1 |  | H | EUGENE C | 0 | 07-027 | FY08-09 | D | EXP0809 | 09-001 |  |  |  |  |  |  |  |  |  |  |  |  |  |  |  |
| 12333025 |  | Re-Baseline Actuals Adjustment |  | 1d | 2013-08-30 A | 2013-08-30 A |  | 100% | 2013-09-03 | 2013-09-03 | PROCUREMENT>$50K 69 NO ESCALATION | 26,474.66 |  |  |  |  | 26474.66 |  |  |  |  |  |  |  |  |  |  |  |  | 0 | 26474.66 | 2647466 | 100 | ADJ |  |  |  |  |  |  |  |  |  |  |
|  | 4 | **1.2.3.4 ELECTRONICS** |  |  | 2006-10-02 | 2013-08-30 |  |  |  |  |  |  |  |  |  |  |  |  |  |  |  |  |  |  |  |  |  |  |  |  |  |  |  |  |  |  |  |  |  |  |  |  |  |  |
| 12341005 |  | Conduct FADC development (FADC) |  | 79d | 2006-10-02 A | 2007-02-01 A | 9-070M | 100% |  |  | CONTRB UNIV LBR [541.2 h]; PROCUREMENT<$50K 60 | 1,032 |  | 2007-09-28 |  |  | 1032 | CHUDAKOV | 1 | 1 | 07-014 | N/A | EUGENE C | 0 |  |  |  |  |  | 0 | 1032 | 103200 | 100 |  | 07-002 | 09-012 |  |  |  |  |  |  |  |  |
| 12342010 |  | Develop clock distribution and synchronization (TDC) |  | 57d | 2006-11-01 A | 2007-02-01 A | 9-070M | 100% | 2006-11-01 | 2007-01-31 | ELEC DES [86.4 h] | 3,886.27 | 3,886.27 | 2007-09-28 |  |  | 3886.26995 | CHUDAKOV | 1 | 1 | 07-014 | N/A | EUGENE C | 0 |  |  |  |  |  |  |  |  |  |  | 07-002 |  |  |  |  |  |  |  |  |  |
| 12343005 |  | Develop plans for trigger integration (TRGR) |  | 57d | 2006-11-01 A | 2007-02-01 A | 9-070M | 100% | 2006-11-01 | 2007-01-31 | CONTRB UNIV LBR [114 h] |  |  | 2007-09-28 |  |  | 0 | CHUDAKOV | 1 | 1 | 07-014 | N/A | EUGENE C |  |  |  |  |  |  |  |  |  |  |  | 07-002 | 09-012 |  |  |  |  |  |  |  |  |
| 12345005 |  | Integrate electronics subsystems (HV) |  | 57d | 2006-11-01 A | 2007-02-01 A | 9-070M | 100% | 2006-11-01 | 2007-01-31 | CONTRB UNIV LBR [40.4 h] |  |  | 2007-09-28 |  |  | 0 | CHUDAKOV | 1 | 1 | 07-014 | N/A | EUGENE C |  |  |  |  |  |  |  |  |  |  |  | 07-002 |  |  |  |  |  |  |  |  |  |
| 12341005A |  | Conduct FADC development (FADC) |  | 168d | 2007-02-01 A | 2007-09-28 A | 12341005 | 100% |  |  | PROCUREMENT<$50K 60; ELEC ENG [421.2 h] | 45,893.98 | 26,285.98 | 2007-09-28 |  |  | 45899.247534 | CHUDAKOV | 1 | 1 | 07-014 | N/A | EUGENE C | 0 |  |  |  |  |  | 0 | 19608 | 1960800 | 100 |  | 07-002 | 09-012 |  |  |  |  |  |  |  |  |
| 12342010A |  | Develop clock distribution and synchronization (TDC) (IPL) |  | 211d | 2007-02-01 A | 2007-11-30 A | 12342010 | 100% |  |  |  |  |  | 2007-09-28 |  |  | 0 | CHUDAKOV | 1 | 1 | 07-014 | N/A | EUGENE C |  |  |  |  |  |  |  |  |  |  |  | 07-002 | 09-012 | IPL |  |  |  |  |  |  |  |
| 12343005A |  | Develop plans for trigger integration (TRGR) |  | 211d | 2007-02-01 A | 2007-11-30 A | 12343005 | 100% |  |  |  |  |  | 2007-09-28 |  |  | 0 | CHUDAKOV | 1 | 1 | 07-014 | N/A | EUGENE C |  |  |  |  |  |  |  |  |  |  |  | 07-002 | 09-012 |  |  |  |  |  |  |  |  |
| 12345005A |  | Integrate electronics subsystems (HV) |  | 214d | 2007-02-01 A | 2007-12-05 A | 12345005 | 100% |  |  |  |  |  | 2007-09-28 |  |  | 0 | CHUDAKOV | 1 | 1 | 07-014 | N/A | EUGENE C |  |  |  |  |  |  |  |  |  |  |  | 07-002 |  |  |  |  |  |  |  |  |  |
| 12342005 |  | Develop DAQ trigger and electronics integration (TDC) |  | 191d | 2007-03-02 A | 2007-11-30 A | 9-070M | 100% |  |  |  |  |  | 2007-09-28 |  |  | 0 | CHUDAKOV | 1 | 1 | 07-014 | N/A | EUGENE C |  |  |  |  |  |  |  |  |  |  |  | 07-002 | 09-012 |  |  |  |  |  |  |  |  |
| 12342005A |  | Develop DAQ trigger and electronics integration (TDC) |  | 184d | 2007-12-03 A | 2008-08-29 A | 12342005 | 100% |  |  |  |  |  | 2007-09-28 |  |  | 0 | CHUDAKOV | 1 | 1 | 07-014 | N/A | EUGENE C |  |  |  |  |  |  |  |  |  |  |  | 07-002 | 09-012 |  |  |  |  |  |  |  |  |
| 1234085 |  | Specification of Crates Backplane, Pwr Supply, remote sensing (Electrnc's) |  | 168d | 2008-01-03 A | 2008-08-29 A | 1154010A, 9-090M, 12345005A | 100% |  |  | CONTRB UNIV LBR [1320 h] |  |  |  |  |  | 0 | CHUDAKOV | 1 | 1 |  | N/A | EUGENE C |  | 07-027 |  |  |  |  |  |  |  |  |  |  |  |  |  |  |  |  |  |  |  |
| 1234090 |  | Dsgn Layout of Crates on Detector & Racks (Electrnc's) |  | 144d | 2008-01-03 A | 2008-07-28 A | 1234075 | 100% |  |  | CONTRB UNIV LBR [1240 h] |  |  |  |  |  | 0 | CHUDAKOV | 1 | 1 |  | N/A | EUGENE C |  | 07-027 |  |  |  |  |  |  |  |  |  |  |  |  |  |  |  |  |  |  |  |
| 1234030 |  | Dsgn Energy Sum Board (Electrnc's) (IPL) |  | 230d | 2008-01-14 A | 2008-12-09 A | 1154045, 9-090M | 100% |  |  | ELEC DES [480 h]; PROCUREMENT<$50K 60; ELEC ENG [1668 h] | 142,519.68 | 126,036.3 |  |  |  | 145689.416603 | CHUDAKOV | 1 | 1 |  | N/A | EUGENE C | 0 | 07-027 |  |  |  |  | 0 | 16483.38 | 1648338 | 100 |  |  |  | IPL |  |  |  |  |  |  |  |
| 1234045 |  | Programing of FADCs for Testing (Electrnc's) |  | 137d | 2008-01-14 A | 2008-07-28 A | 1234040 | 100% |  |  | SCIENTIST [200 h] | 12,454 | 12,454 |  |  |  | 12852 | CHUDAKOV | 1 | 1 |  | N/A | EUGENE C | 0 | 07-027 | FY08-09 |  |  |  |  |  |  |  |  |  |  |  |  |  |  |  |  |  |  |
| 1234070 |  | Dsgn Energy Sum collections into Trigger (Electrnc's) |  | 164d | 2008-01-14 A | 2008-09-04 A | 1234065 FS-20d | 100% |  |  | ELEC DES [440 h] | 19,602 | 19,602 |  |  |  | 19602 | CHUDAKOV | 1 | 1 |  | N/A | EUGENE C | 0 | 07-027 |  |  |  |  |  |  |  |  |  |  |  |  |  |  |  |  |  |  |  |
| 1234075 |  | Dsgn Track Count Collection into Trigger (Electrnc's) (IPL) |  | 164d | 2008-01-14 A | 2008-09-04 A | 1234070 | 100% |  |  | CONTRB UNIV LBR [1320 h] |  |  |  |  |  | 0 | CHUDAKOV | 1 | 1 |  | N/A | EUGENE C |  | 07-027 |  |  |  |  |  |  |  |  |  |  |  | IPL |  |  |  |  |  |  |  |
| 1234080 |  | PROC Dsgn Master Trigger (Electrnc's) |  | 179d | 2008-01-14 A | 2008-09-25 A | 1234075, 1154040 | 100% |  |  | PROCUREMENT<$50K 60 NO ESCALATION FY09 | 56,444.93 |  |  |  |  | 56444.93 | CHUDAKOV | 1 | 1 |  | N/A | EUGENE C | 0 | 07-027 | FY08-09 | D | EXP0809 | 09-001 | 0 | 56444.93 | 5644493 | 100 |  |  | 09-012 |  | 08-016 |  |  |  |  |  |  |
| 1234080a |  | FY08 LAB/EXP Dsgn Master Trigger (Electrnc's) |  | 3d | 2008-01-14 A | 2008-01-16 A | 1154040, 1234075 | 100% |  |  | SCIENTIST [21.23 h] | 1,321.99 | 1,321.99 |  |  |  | 1321.9921 | CHUDAKOV | 1 | 1 |  | N/A | EUGENE C | 0 | 07-027 | FY08-09 | D | EXP0809 | 09-001 |  |  |  |  |  |  | 09-012 |  | 08-016 |  |  |  |  |  |  |
| 1234110 |  | Specify HV & Low Voltage Supplies (Electrnc's) |  | 137d | 2008-01-14 A | 2008-07-28 A | 1154055, 9-090M | 100% |  |  | ELEC ENG [400 h] | 24,896 | 24,896 |  |  |  | 25692 | CHUDAKOV | 1 | 1 |  | N/A | EUGENE C | 0 | 07-027 | FY08-09 |  |  |  |  |  |  |  |  |  | 09-012 |  |  | 07-024 |  |  |  |  |  |
| 1234080b |  | FY09 LAB/EXP Dsgn Master Trigger (Electrnc's) |  | 176d | 2008-01-17 A | 2008-09-25 A | 1234080a | 100% |  |  | SCIENTIST [898.77 h] | 55,966.41 | 55,966.41 |  |  |  | 57754.9602 | CHUDAKOV | 1 | 1 |  | N/A | EUGENE C | 0 | 07-027 | FY08-09 | D | EXP0809 | 09-001 |  |  |  |  |  |  | 09-012 |  | 08-016 |  |  |  |  |  |  |
| 1234095 |  | Dsgn Grounding Scheme of Crates & Racks (Electrnc's) |  | 185d | 2008-04-01 A | 2008-12-22 A | 1234090 | 100% |  |  | ELEC ENG [200 h] | 12,570.63 | 12,570.63 |  |  |  | 12846 | CHUDAKOV | 1 | 1 |  | H | EUGENE C | 0 |  |  |  |  |  |  |  |  |  |  |  | 09-012 |  |  | 07-024 |  |  |  |  |  |
| 1234100 |  | Dsgn networking of Crates (Electrnc's) |  | 306d | 2008-04-01 A | 2009-06-22 A | 1234095 | 100% |  |  | ELEC ENG [320 h] | 20,287.23 | 20,287.23 |  |  |  | 20553.6 | CHUDAKOV | 1 | 1 |  | H | EUGENE C | 0 |  |  |  |  |  |  |  |  |  |  |  | 09-012 |  |  | 07-024 |  |  |  |  |  |
| 1234105 |  | Dsgn Global Signal Distrbtn Interface to FADCs & TDCs (Electrnc's) |  | 242d | 2008-04-01 A | 2009-03-23 A | 1234100 | 100% |  |  | ELEC ENG [320 h] | 20,216.78 | 20,216.78 |  |  |  | 20553.6 | CHUDAKOV | 1 | 1 |  | H | EUGENE C | 0 |  |  |  |  |  |  |  |  |  |  |  | 09-012 |  |  | 07-024 |  |  |  |  |  |
| 1234035 |  | Dsgn Crate Clock Distrbtn for FADCs (Electrnc's) |  | 72d | 2008-09-25 A | 2009-01-14 A | 1234030, 1154050 | 100% |  |  | ELEC DES [400 h] | 18,360.22 | 18,360.22 |  |  |  | 18392 | CHUDAKOV | 1 | 1 |  | H | EUGENE C | 0 | 07-027 |  |  |  |  |  |  |  |  |  |  |  |  |  |  |  |  |  |  |  |
| 1234040 |  | Dsgn Cabling & Layout for FADCs (Electrnc's) |  | 61d | 2008-09-25 A | 2008-12-22 A | 1234035 | 100% |  |  | ELEC TECH [880 h] | 35,278.05 | 35,278.05 |  |  |  | 35349.6 | CHUDAKOV | 1 | 1 |  | H | EUGENE C | 0 | 07-027 |  |  |  |  |  |  |  |  |  |  |  |  |  |  |  |  |  |  |  |
| 1234115 |  | FY08 Specify Discriminators & Logic for DAQ/Trigger Integration (Electrnc's) |  | 98d | 2008-12-01 A | 2009-04-27 A | 1154060 | 100% |  |  | ELEC ENG [24 h] | 1,541.52 | 1,541.52 |  |  |  | 1493.76 | CHUDAKOV | 1 | 1 |  | H | EUGENE C | 0 |  | FY08-09 | D | EXP0809 | 09-001 |  |  |  |  |  |  | 09-012 |  |  | 07-024 |  |  |  |  |  |
| 1545009EX |  | FY09 Travel (LOGIC, HV) |  | 16d | 2008-12-01 A | 2008-12-22 A | 9-090M | 100% |  |  | TRAVEL | 303.85 |  |  | 100 | 100 | 303.85 | CHUDAKOV | 1 | 1 |  | E | EUGENE C | 0 | 07-027 |  | D |  |  |  |  |  |  |  |  |  |  |  | 07-024 | 08-058 | 11-006 | 11-026 | 11-029 |  |
| 1234115a |  | FY09 Specify Discriminators & Logic for DAQ/Trigger Integration (Electrnc's) |  | 92d | 2008-12-02 A | 2009-04-20 A | 1154060, 1234115 FS-250d | 100% |  |  | ELEC ENG [136 h] | 8,735.28 | 8,735.28 |  |  |  | 8735.28 | CHUDAKOV | 1 | 1 |  | H | EUGENE C | 0 |  | FY08-09 | D | EXP0809 | 09-001 |  |  |  |  |  |  | 09-012 |  |  | 07-024 |  |  |  |  |  |
| 1234050 |  | TDC Version II: Dsgn & Proto (Electrnc's) |  | 73d | 2009-01-05 A | 2009-04-20 A | 12342005A FS-85d, 12343005A, 12342010A, 12341005A, 1154005A | 100% | 2009-01-05 | 2009-04-17 | CONTRB UNIV LBR [560 h] |  |  |  |  |  | 0 | CHUDAKOV | 1 | 1 |  | Z | EUGENE C |  | 07-027 |  |  |  |  |  |  |  |  |  |  |  |  |  |  |  |  |  |  |  |
| 1234060 |  | Dsgn Clock Distrbtn for TDC Sys (Electrnc's) |  | 79d | 2009-01-05 A | 2009-04-27 A | 1234055 FS-250d | 100% |  |  | ELEC DES [440 h] | 20,231.2 | 20,231.2 |  |  |  | 19602 | CHUDAKOV | 1 | 1 |  | H | EUGENE C | 0 | 07-027 |  |  |  |  |  |  |  |  |  |  |  |  |  |  |  |  |  |  |  |
| 1234065 |  | Dsgn Cabling & Layout for TDC Sys (Electrnc's) |  | 53d | 2009-01-05 A | 2009-03-23 A | 1234060 FS-250d | 100% | 2009-01-05 | 2009-03-20 | ELEC TECH [880 h] | 35,349.6 | 35,349.6 |  |  |  | 34258.4 | CHUDAKOV | 1 | 1 |  | H | EUGENE C | 0 | 07-027 |  |  |  |  |  |  |  |  |  |  |  |  |  |  |  |  |  |  |  |
| 1234159 |  | Final Dsgn & Safty Assessmnt of Electrnc's |  | 54d | 2009-01-05 A | 2009-03-23 A | 1234075, 1234110 FS-250d, 1234105 FS-250d, 1234045, 1234080, 1234040, 1234085, 1234115a FS-250d, 1234080b | 100% |  |  |  |  |  |  |  |  | 0 | CHUDAKOV | 1 | 1 |  | Z | EUGENE C |  |  |  |  |  |  |  |  |  |  |  |  |  |  |  |  |  |  |  |  |  |
| 1234180M |  | Electrnc's Dsgn Rquirmnts Finalized++ | milestone | 0d | 2009-03-23 A | 2009-03-23 A | 1234159 FS+13d | 100% | 2009-05-05 | 2009-05-05 |  |  |  |  |  |  | 0 | CHUDAKOV | 1 | 1 |  | M | EUGENE C |  | 07-027 |  | D |  |  |  |  |  |  |  |  |  |  |  |  |  |  |  |  | 6 |
| 1234055 |  | TDC Version II: Test, Evaluate (Electrnc's) |  | 14d | 2009-04-01 A | 2009-04-20 A | 1234050 | 100% |  |  | SCIENTIST [200 h] | 12,852 | 12,852 |  |  |  | 12454 | CHUDAKOV | 1 | 1 |  | H | EUGENE C | 0 | 07-027 |  |  |  |  |  |  |  |  |  |  |  |  |  |  |  |  |  |  |  |
| 12345010 |  | Re-Baseline Actuals Adjustment |  | 1d | 2013-08-30 A | 2013-08-30 A |  | 100% | 2013-09-03 | 2013-09-03 | PROCUREMENT>$50K 69 NO ESCALATION | 80,956.11 |  |  |  |  | 80956.11 |  |  |  |  |  |  |  |  |  |  |  |  | 0 | 80956.11 | 8095611 | 100 | ADJ |  |  |  |  |  |  |  |  |  |  |

Notes:
- 12342010: TEST of New Cat: Remove $20K worth of Elect Designers / time. ask will
- 12342010A: TEST of New Cat: Remove $20K worth of Elect Designers / time. ask will

| ID | WBS | Activity | Type | Duration | Start | Finish | Predecessors | Complete | Planned start | Planned finish | Constraint | Resources | Cost | Actual cost | MONTHLY EV COST | RESP - Responsibility | STRT%COMP for CM EVM | FNSH%COMP for CM EVM | CR 07-027 | EVMS Reporting Codes | CAM RESPONSIBLE | Milestone Level | HALL D Related Milestones | Planned FinishUDF | LOE Divider | LOE Multiplier | Calculated Remaining Total Cost | CR 07-014 | CR 09-012 | ACT BRIDGING FY SPLIT | Remaining Material Cost Based on % Compl | Claimed Material Cost Based on % Complet | Initial Claimed Material Calc | Claimed Material Divider | CR 08-016 | EXPNS ACT BRIDGING FY SPLIT | CR 09-001 | ReBaseline Actuals Adjustment |
| --- | --- | --- | --- | --- | --- | --- | --- | --- | --- | --- | --- | --- | --- | --- | --- | --- | --- | --- | --- | --- | --- | --- | --- | --- | --- | --- | --- | --- | --- | --- | --- | --- | --- | --- | --- | --- | --- | --- |
|  | 1 | **1.2.3.4.1 FADC** |  |  |  |  |  |  |  |  |  |  |  |  |  |  |  |  |  |  |  |  |  |  |  |  |  |  |  |  |  |  |  |  |  |  |  |  |
|  | 2 | **1.2.3.4.2 TDC** |  |  |  |  |  |  |  |  |  |  |  |  |  |  |  |  |  |  |  |  |  |  |  |  |  |  |  |  |  |  |  |  |  |  |  |  |
|  | 3 | **1.2.3.4.3 TRIGGER** |  |  |  |  |  |  |  |  |  |  |  |  |  |  |  |  |  |  |  |  |  |  |  |  |  |  |  |  |  |  |  |  |  |  |  |  |
|  | 4 | **1.2.3.4.4 CRATES** |  |  |  |  |  |  |  |  |  |  |  |  |  |  |  |  |  |  |  |  |  |  |  |  |  |  |  |  |  |  |  |  |  |  |  |  |
|  | 5 | **1.2.3.4.5 HV** |  |  |  |  |  |  |  |  |  |  |  |  |  |  |  |  |  |  |  |  |  |  |  |  |  |  |  |  |  |  |  |  |  |  |  |  |
|  | 5 | **1.2.3.5 BEAMLINE** |  |  | 2006-10-02 | 2013-08-30 |  |  |  |  |  |  |  |  |  |  |  |  |  |  |  |  |  |  |  |  |  |  |  |  |  |  |  |  |  |  |  |  |
|  | 1 | **1.2.3.5.1 TAGGER** |  |  | 2006-10-02 | 2013-08-30 |  |  |  |  |  |  |  |  |  |  |  |  |  |  |  |  |  |  |  |  |  |  |  |  |  |  |  |  |  |  |  |  |
| 12351054 |  | Final Dsgn & Safty Assessmnt of Tagger |  | 34d | 2008-11-03 A | 2008-12-22 A | 123511045, 123512050, 123511050, 123512040, 123512035, 123512045, 123511050b | 100% |  |  |  |  |  |  | 0 | CHUDAKOV | 1 | 1 | 07-027 | Z | EUGENE C |  |  |  |  |  |  |  |  |  |  |  |  |  |  |  |  |  |
| 12351055M |  | Tagger Dsgn Rquirmnts Finalized++ | milestone | 0d | 2008-12-22 A | 2008-12-22 A | 12351054 | 100% | 2009-05-04 | 2009-05-04 |  |  |  |  | 0 | CHUDAKOV | 1 | 1 | 07-027 | M | EUGENE C | 6 | D |  |  |  |  |  |  |  |  |  |  |  |  |  |  |  |
|  | 1 | **1.2.3.5.1.1 TAGGING MAGNET** |  |  | 2006-10-02 | 2013-08-30 |  |  |  |  |  |  |  |  |  |  |  |  |  |  |  |  |  |  |  |  |  |  |  |  |  |  |  |  |  |  |  |  |
| 123511005LOE |  | Develop design and procurement strategies (TAGMAG) |  | 79d | 2006-10-02 A | 2007-02-01 A | 9-070M | 100% |  |  |  | CONTRB UNIV LBR [101.6 h]; PD UNIV STAFF [489.6 h] | 24,494.68 | 24,494.69 | 24494.675081 | CHUDAKOV | 1 | 1 |  | N/A | EUGENE C |  |  | 2007-09-28 | 100 | 100 | 0 | 07-014 |  |  |  |  |  |  |  |  |  |  |
| 123511005ALOE |  | Develop design and procurement strategies (TAGMAG) |  | 288d | 2007-02-01 A | 2008-03-31 A | 123511005LOE | 100% |  |  | start on or after 2007-02-02 | PD UNIV STAFF [830.4 h] | 41,018.74 | 41,018.74 | 40917.944088 | CHUDAKOV | 1 | 1 | 07-027 | N/A | EUGENE C |  |  | 2007-09-28 | 100 | 100 | 0 | 07-014 | 09-012 |  |  |  |  |  |  |  |  |  |
| 123511005 |  | Develop design and procurement strategies (TAGMAG) |  | 127d | 2007-04-02 A | 2007-09-28 A | 9-070M | 100% |  |  |  |  |  |  | 0 | CHUDAKOV | 1 | 1 |  | N/A | EUGENE C |  |  | 2007-09-28 |  |  |  | 07-014 | 09-012 |  |  |  |  |  |  |  |  |  |
| 123511010 |  | Top Level Drawings of Quad, Two Dipoles & Vac Sys (TAG MAG) |  | 323d | 2007-11-01 A | 2009-02-27 A | 123511005ALOE FS-120d, 123511005 FS-120d | 100% |  |  |  | CONTRB UNIV LBR [300 h]; VISTNG USERS [160 h] | 2,753.1 | 2,753.1 | 2753.6 | CHUDAKOV | 1 | 1 | 07-027 | N/A | EUGENE C |  |  |  |  |  | 0 |  |  |  |  |  |  |  |  |  |  |  |
| 123511020 |  | Top view of a Dipole Showing bolt locations (TAG MAG) |  | 323d | 2007-11-01 A | 2009-02-27 A | 123511015 | 100% |  |  |  | PD UNIV STAFF [440 h]; VISTNG USERS [160 h] | 24,770.43 | 24,770.43 | 24027.888 | CHUDAKOV | 1 | 1 | 07-027 | N/A | EUGENE C |  |  |  |  |  | 0 |  |  |  |  |  |  |  |  |  |  |  |
| 123511025 |  | Individual Drawings for Poleshoes (TAG MAG) |  | 323d | 2007-11-01 A | 2009-02-27 A | 123511020 FS-10d | 100% |  |  |  | VISTNG USERS [160 h]; PD UNIV STAFF [440 h] | 24,770.43 | 24,770.43 | 24532.8 | CHUDAKOV | 1 | 1 | 07-027 | N/A | EUGENE C |  |  |  |  |  | 0 |  |  |  |  |  |  |  |  |  |  |  |
| 123511030 |  | Drawings Showing All Different Types of Brackets (TAG MAG) |  | 323d | 2007-11-01 A | 2009-02-27 A | 123511025 FS-10d | 100% |  |  |  | PD UNIV STAFF [440 h]; VISTNG USERS [160 h] | 24,770.43 | 24,770.43 | 24532.8 | CHUDAKOV | 1 | 1 | 07-027 | N/A | EUGENE C |  |  |  |  |  | 0 |  |  |  |  |  |  |  |  |  |  |  |
| 123511035 |  | Layout of Vac Chamb (TAG MAG) |  | 323d | 2007-11-01 A | 2009-02-27 A | 123511030 FS-10d | 100% |  |  |  | VISTNG USERS [160 h]; PD UNIV STAFF [440 h] | 24,770.43 | 24,770.43 | 24532.8 | CHUDAKOV | 1 | 1 | 07-027 | N/A | EUGENE C |  |  |  |  |  | 0 |  |  | FY08-09 |  |  |  |  |  |  |  |  |
| 123511015 |  | Vertical Section through a Dipole Showing how Poleshoes & Yoke (TAG MAG) |  | 278d | 2008-01-16 A | 2009-02-27 A | 123511010 | 100% |  |  |  | PD UNIV STAFF [440 h]; VISTNG USERS [160 h] | 24,808.89 | 24,808.89 | 24039.7968 | CHUDAKOV | 1 | 1 | 07-027 | N/A | EUGENE C |  |  |  |  |  | 0 |  |  |  |  |  |  |  |  |  |  |  |
| 123511040 |  | Drawings of Top & Bottom Lids, & Back-Wall of Vac Chamb (TAG MAG) |  | 330d | 2008-04-01 A | 2009-07-27 A | 123511035 FS-10d | 100% |  |  |  | PD UNIV STAFF [440 h]; VISTNG USERS [160 h] | 25,012.22 | 25,012.22 | 24532.8 | CHUDAKOV | 1 | 1 | 07-027 | H | EUGENE C |  |  |  |  |  | 0 |  |  |  |  |  |  |  |  |  |  |  |
| 123511045 |  | Drawings Showing Assy & Dis-assy of Mag (TAG MAG) |  | 330d | 2008-04-01 A | 2009-07-27 A | 123511040 FS-125d | 100% |  |  |  | PROCUREMENT<$50K 60; VISTNG USERS [440 h] | 35,651.5 | 7,645.73 | 35503.366 | CHUDAKOV | 1 | 1 | 07-027 | H | EUGENE C |  |  |  |  |  | 0 |  |  |  | 0 | 28005.77 | 2800577 | 100 |  |  |  |  |
| 123511050 |  | PROC Production of Drawings for Strong Back Supprt for Dipole Magnets. (TAG MAG) |  | 330d | 2008-04-01 A | 2009-07-27 A | 123511045 FS-125d | 100% |  |  |  | PROCUREMENT<$50K 60 NO ESCALATION FY09 | 26,623.02 |  | 26623.02 | CHUDAKOV | 1 | 1 | 07-027 | H | EUGENE C |  | D |  |  |  | 0 |  | 09-012 |  | 0 | 26623.02 | 2662302 | 100 | 08-016 | EXP0809 | 09-001 |  |
| 123511050a |  | FY08 LAB/EXP Production of Drawings for Strong Back Supprt for Dipole Magnets. (TAG MAG) |  | 8d | 2008-04-01 A | 2008-04-10 A | 123511045 FS-125d | 100% |  |  |  | VISTNG USERS [78.22 h] | 1,332.87 | 1,332.87 | 1332.8688 | CHUDAKOV | 1 | 1 | 07-027 | H | EUGENE C |  | D |  |  |  | 0 |  | 09-012 |  |  |  |  |  | 08-016 | EXP0809 | 09-001 |  |
| 123511050b |  | FY09 LAB/EXP Production of Drawings for Strong Back Supprt for Dipole Magnets. (TAG MAG) |  | 322d | 2008-04-11 A | 2009-07-27 A | 123511050a FS-125d | 100% |  |  |  | VISTNG USERS [361.78 h] | 6,289.56 | 6,289.56 | 6363.7102 | CHUDAKOV | 1 | 1 | 07-027 | H | EUGENE C |  | D |  |  |  | 0 |  | 09-012 |  |  |  |  |  | 08-016 | EXP0809 | 09-001 |  |
| 123511055 |  | Re-Baseline Actuals Adjustment |  | 1d | 2013-08-30 A | 2013-08-30 A |  | 100% | 2013-09-03 | 2013-09-03 |  | PROCUREMENT>$50K 69 NO ESCALATION | -111,185.11 |  |  |  |  |  |  |  |  |  |  |  |  |  |  |  |  |  |  |  |  | 100 |  |  |  | ADJ |

Notes:
- 123511050a: Explanation: 29May2009 Added -25w of lag to / close up gap in progress / bar.

| ID | WBS | Activity | Type | Duration | Start | Finish | Predecessors | Complete | Planned start | Planned finish | Constraint | Resources | Cost | Actual cost | Planned FinishUDF | MONTHLY EV COST | RESP - Responsibility | STRT%COMP for CM EVM | FNSH%COMP for CM EVM | CR 07-014 | EVMS Reporting Codes | CAM RESPONSIBLE | CR 09-012 | CR 07-027 | ACT BRIDGING FY SPLIT | Calculated Remaining Total Cost | HALL D Related Milestones | EXPNS ACT BRIDGING FY SPLIT | CR 09-001 | Milestone Level | Claimed Material Divider | ReBaseline Actuals Adjustment |
| --- | --- | --- | --- | --- | --- | --- | --- | --- | --- | --- | --- | --- | --- | --- | --- | --- | --- | --- | --- | --- | --- | --- | --- | --- | --- | --- | --- | --- | --- | --- | --- | --- |
|  | 2 | **1.2.3.5.1.2 HODOSCOPE** |  |  | 2006-11-01 | 2009-02-23 |  |  |  |  |  |  |  |  |  |  |  |  |  |  |  |  |  |  |  |  |  |  |  |  |  |  |
| 123512005 |  | Develop design for the spectrometer hodoscope (HODO) |  | 58d | 2006-11-01 A | 2007-02-01 A | 9-070M | 100% |  |  |  | CONTRB UNIV LBR [504.4 h] |  |  | 2007-09-28 | 0 | CHUDAKOV | 1 | 1 | 07-014 | N/A | EUGENE C |  |  |  |  |  |  |  |  |  |  |
| 123512005A |  | Develop design for the spectrometer hodoscope (HODO) |  | 246d | 2007-02-02 A | 2008-01-31 A | 123512005 | 100% |  |  |  |  |  |  | 2007-09-28 | 0 | CHUDAKOV | 1 | 1 | 07-014 | N/A | EUGENE C | 09-012 |  |  |  |  |  |  |  |  |  |
| 123512010 |  | Dsgn Light Guides for Microscope (HODO) |  | 101d | 2008-09-22 A | 2009-02-23 A | 1155005A FS-60d, 123512005A | 100% |  |  |  | CONTRB UNIV LBR [320 h] |  |  |  | 0 | CHUDAKOV | 1 | 1 |  | Z | EUGENE C |  | 07-027 |  |  |  |  |  |  |  |  |
| 123512015 |  | Dsgn Frame for Microscope (HODO) |  | 101d | 2008-09-22 A | 2009-02-23 A | 1155005A FS-60d, 123512005A | 100% |  |  |  | CONTRB UNIV LBR [320 h] |  |  |  | 0 | CHUDAKOV | 1 | 1 |  | Z | EUGENE C |  | 07-027 |  |  |  |  |  |  |  |  |
| 123512040 |  | Dsgn Alignment for Microscope (HODO) |  | 99d | 2008-09-24 A | 2009-02-23 A | 123512010, 123512015 | 100% |  |  |  | CONTRB UNIV LBR [280 h] |  |  |  | 0 | CHUDAKOV | 1 | 1 |  | Z | EUGENE C |  | 07-027 | FY08-09 |  |  |  |  |  |  |  |
| 123512045 |  | Dsgn Cable Layout for Microscope (HODO) |  | 99d | 2008-09-24 A | 2009-02-23 A | 123512015, 123512010 | 100% |  |  |  | CONTRB UNIV LBR [120 h] |  |  |  | 0 | CHUDAKOV | 1 | 1 |  | Z | EUGENE C |  | 07-027 |  |  |  |  |  |  |  |  |
| 123512020 |  | Dsgn Frame for Fixed Array (HODO) |  | 71d | 2008-11-03 A | 2009-02-23 A | 123512005A, 1155005A FS-60d | 100% |  |  |  | CONTRB UNIV LBR [320 h] |  |  |  | 0 | CHUDAKOV | 1 | 1 |  | Z | EUGENE C |  | 07-027 |  |  |  |  |  |  |  |  |
| 123512025 |  | Dsgn Voltage Divider for Fixed Array PMT (HODO) |  | 71d | 2008-11-03 A | 2009-02-23 A | 1155005A FS-60d, 123512005A | 100% |  |  |  | CONTRB UNIV LBR [320 h] |  |  |  | 0 | CHUDAKOV | 1 | 1 |  | Z | EUGENE C |  | 07-027 |  |  |  |  |  |  |  |  |
| 123512030 |  | Dsgn Light Guides for Fixed Array (HODO) |  | 71d | 2008-11-03 A | 2009-02-23 A | 1155005A FS-60d, 123512005A | 100% |  |  |  | CONTRB UNIV LBR [320 h] |  |  |  | 0 | CHUDAKOV | 1 | 1 |  | Z | EUGENE C |  | 07-027 |  |  |  |  |  |  |  |  |
| 123512035 |  | Determine Assy Procedure for Fixed Array (HODO) |  | 71d | 2008-11-03 A | 2009-02-23 A | 123512020, 123512030, 123512025 | 100% |  |  |  | CONTRB UNIV LBR [320 h] |  |  |  | 0 | CHUDAKOV | 1 | 1 |  | Z | EUGENE C |  | 07-027 |  |  |  |  |  |  |  |  |
| 123512050 |  | Dsgn Cable Layout for Fixed Array (HODO) |  | 71d | 2008-11-03 A | 2009-02-23 A | 123512010, 123512015 | 100% |  |  |  | CONTRB UNIV LBR [160 h] |  |  |  | 0 | CHUDAKOV | 1 | 1 |  | Z | EUGENE C |  | 07-027 |  |  |  |  |  |  |  |  |
|  | 2 | **1.2.3.5.2 TARGET** |  |  |  |  |  |  |  |  |  |  |  |  |  |  |  |  |  |  |  |  |  |  |  |  |  |  |  |  |  |  |
|  | 3 | **1.2.3.5.3 BEAMLINE COMPONENTS** |  |  | 2006-11-01 | 2013-08-30 |  |  |  |  |  |  |  |  |  |  |  |  |  |  |  |  |  |  |  |  |  |  |  |  |  |  |
| 12353005 |  | Develop design for active collimator (BL COMPONENTS) |  | 57d | 2006-11-01 A | 2007-02-01 A | 9-070M | 100% | 2006-11-01 | 2007-01-31 |  | CONTRB UNIV LBR [116 h] |  |  | 2007-09-28 | 0 | CHUDAKOV | 1 | 1 | 07-014 | N/A | EUGENE C | 09-012 |  |  |  |  |  |  |  |  |  |
| 12353005A |  | Develop design for active collimator (BL COMPONENTS) |  | 247d | 2007-02-01 A | 2008-01-31 A | 12353005 | 100% |  |  | start on or after 2007-02-02 | PD UNIV STUDNT [320 h] | 3,045.12 | 3,045.12 | 2007-09-28 | 3041.817075 | CHUDAKOV | 1 | 1 | 07-014 | N/A | EUGENE C | 09-012 | 07-027 |  | 0 |  |  |  |  |  |  |
| 12353030 |  | Dsgn BL Configuration (BL Compnts) |  | 99d | 2008-06-09 A | 2008-10-27 A | 1155010A FS-80d, 12353005A FS-120d, 12353025a FS-120d | 100% |  |  |  | SCIENTIST [440 h] | 27,566.84 | 27,566.84 |  | 28274.4 | CHUDAKOV | 1 | 1 |  | H | EUGENE C |  | 07-027 |  | 0 |  |  |  |  |  |  |
| 12353010 |  | Dsgn Active Collimator (BL Compnts) |  | 122d | 2008-07-28 A | 2009-01-27 A | 1155010A FS-80d, 12353005A FS-120d | 100% |  |  |  | CONTRB UNIV LBR [488 h] |  |  |  | 0 | CHUDAKOV | 1 | 1 |  | Z | EUGENE C |  | 07-027 |  |  |  |  |  |  |  |  |
| 12353015 |  | Dsgn Photon Monitor (BL Compnts) |  | 103d | 2008-07-28 A | 2008-12-22 A | 12353005A FS-120d, 1155010A FS-80d | 100% |  |  |  | PD UNIV STUDNT [312 h] | 2,987.72 | 2,987.72 |  | 2935.92 | CHUDAKOV | 1 | 1 |  | H | EUGENE C |  | 07-027 |  | 0 |  |  |  |  |  |  |
| 12353020 |  | Dsgn Feedback Mechanism (BL Compnts) |  | 224d | 2008-07-28 A | 2009-06-22 A | 12353010, 12353015 | 100% |  |  |  | SCIENTIST [880 h] | 56,189.18 | 56,189.18 |  | 54797.6 | CHUDAKOV | 1 | 1 |  | N/A | EUGENE C |  | 07-027 |  | 0 |  |  |  |  |  |  |
| 12353025 |  | FY08 Dsgn Display of Beam Position (BL Compnts) |  | 75d | 2008-10-01 A | 2009-01-26 A | 1155010A FS-80d, 12353005A FS-120d | 100% |  |  |  | SCIENTIST [776 h] | 49,865.76 | 49,865.76 |  | 48321.52 | CHUDAKOV | 1 | 1 |  | N/A | EUGENE C |  | 07-027 | FY08-09 | 0 | D | EXP0809 | 09-001 |  |  |  |
| 12353035 |  | Integrate Goniometer into BL (BL Compnts) |  | 114d | 2008-10-01 A | 2009-03-23 A | 1155020, 1155025, 12353030 | 100% |  |  |  | SCIENTIST [440 h] | 28,274.4 | 28,274.4 |  | 28274.4 | CHUDAKOV | 1 | 1 |  | H | EUGENE C |  | 07-027 |  | 0 |  |  |  |  |  |  |
| 12353040 |  | Final Dsgn & Safty Assessmnt of Beam Line Compnts |  | 46d | 2008-11-03 A | 2009-01-15 A | 12353035, 12353020 | 100% |  |  |  |  |  |  |  | 0 | CHUDAKOV | 1 | 1 |  | Z | EUGENE C |  | 07-027 |  |  |  |  |  |  |  |  |
| 12353045M |  | Beam Line Components Dsgn Rquirmnts Finalized | milestone | 0d | 2009-01-15 A | 2009-01-15 A | 12353040 FS+13d | 100% | 2009-05-04 | 2009-05-04 |  |  |  |  |  | 0 | CHUDAKOV | 1 | 1 |  | M | EUGENE C |  | 07-027 |  |  | D |  |  | 6 |  |  |
| 12353025a |  | FY09 Dsgn Display of Beam Position (BL Compnts) |  | 17d | 2009-05-29 A | 2009-06-22 A | 12353025 | 100% |  |  |  | SCIENTIST [104 h] | 6,683.04 | 6,683.04 |  | 6683.04 | CHUDAKOV | 1 | 1 |  | N/A | EUGENE C |  | 07-027 | FY08-09 | 0 | D | EXP0809 | 09-001 |  |  |  |
| 12353050 |  | Re-Baseline Actuals Adjustment |  | 1d | 2013-08-30 A | 2013-08-30 A |  | 100% | 2013-09-03 | 2013-09-03 |  | PROCUREMENT>$50K 69 NO ESCALATION | -4,368.15 |  |  |  |  |  |  |  |  |  |  |  |  |  |  |  |  |  | 100 | ADJ |

| ID | WBS | Activity | Type | Duration | Start | Finish | Predecessors | Complete | Planned start | Planned finish | Resources | Cost | Actual cost | MONTHLY EV COST | RESP - Responsibility | STRT%COMP for CM EVM | FNSH%COMP for CM EVM | Milestone Level | HALL D Related Milestones | CR 07-027 | EVMS Reporting Codes | CAM RESPONSIBLE | Calculated Remaining Total Cost | ACT BRIDGING FY SPLIT | Claimed Material Divider | ReBaseline Actuals Adjustment | Planned FinishUDF | CR 09-012 | Remaining Material Cost Based on % Compl | Claimed Material Cost Based on % Complet | Initial Claimed Material Calc |
| --- | --- | --- | --- | --- | --- | --- | --- | --- | --- | --- | --- | --- | --- | --- | --- | --- | --- | --- | --- | --- | --- | --- | --- | --- | --- | --- | --- | --- | --- | --- | --- |
|  | 6 | **1.2.3.6 INFRASTRUCTURE** |  |  | 2008-10-01 | 2013-08-30 |  |  |  |  |  |  |  |  |  |  |  |  |  |  |  |  |  |  |  |  |  |  |  |  |  |
|  | 1 | **1.2.3.6.1 ASSEMBLY** |  |  | 2008-10-01 | 2013-08-30 |  |  |  |  |  |  |  |  |  |  |  |  |  |  |  |  |  |  |  |  |  |  |  |  |  |
| 12361000M |  | Starting Milestone for FY09 (Assy) | milestone | 0d | 2008-10-01 A | 2008-10-01 A | 9-090M | 100% | 2008-11-03 | 2008-11-03 |  |  |  | 0 | CHUDAKOV | 1 | 1 | 6 | D | 07-027 | M | EUGENE C |  |  |  |  |  |  |  |  |  |
| 12361005 |  | Develop Alignment of DCs (Assy)+ |  | 109d | 2008-10-01 A | 2009-03-16 A | 12361000M | 100% |  |  | MECH TECH [440 h] | 17,798 | 17,798 | 17798 | CHUDAKOV | 1 | 1 |  |  | 07-027 | H | EUGENE C | 0 |  |  |  |  |  |  |  |  |
| 12361010 |  | Develop Installtn of Bcal (Assy)+ |  | 109d | 2008-10-01 A | 2009-03-16 A | 12361000M | 100% |  |  | MECH TECH [440 h] | 17,798 | 17,798 | 17798 | CHUDAKOV | 1 | 1 |  |  | 07-027 | H | EUGENE C | 0 | FY08-09 |  |  |  |  |  |  |  |
| 12361015 |  | Re-Baseline Actuals Adjustment |  | 1d | 2013-08-30 A | 2013-08-30 A |  | 100% | 2013-09-03 | 2013-09-03 | PROCUREMENT>$50K 69 NO ESCALATION | -1,986.49 |  |  |  |  |  |  |  |  |  |  |  |  | 100 | ADJ |  |  |  |  |  |
|  | 2 | **1.2.3.6.2 INSTALLATION** |  |  |  |  |  |  |  |  |  |  |  |  |  |  |  |  |  |  |  |  |  |  |  |  |  |  |  |  |  |
|  | 3 | **1.2.3.6.3 CRYOGENICS** |  |  |  |  |  |  |  |  |  |  |  |  |  |  |  |  |  |  |  |  |  |  |  |  |  |  |  |  |  |
|  | 4 | **1.2.4 CONVENTIONAL FACILITIES** |  |  | 2006-10-02 | 2013-08-30 |  |  |  |  |  |  |  |  |  |  |  |  |  |  |  |  |  |  |  |  |  |  |  |  |  |
|  | 1 | **1.2.4.1 ACCELERATOR** |  |  | 2006-10-02 | 2013-08-30 |  |  |  |  |  |  |  |  |  |  |  |  |  |  |  |  |  |  |  |  |  |  |  |  |  |
| 1241000M |  | Begin Design N&S Access Building Additions | milestone | 0d | 2006-10-02 A | 2006-10-02 A | 9-070M | 100% |  |  |  |  |  | 0 | WHITLATCH C | 1 | 1 | 9 |  |  | N/A | REBECCA Y |  |  |  |  | 2006-10-02 |  |  |  |  |
| 1241005 |  | Develop N&S Addition Preliminary Design (ACCEL) |  | 31d | 2006-10-10 A | 2006-11-21 A | 1241000M | 100% |  |  | PLANT ENG [40 h] | 2,501.6 | 2,501.6 | 2501.6 | WHITLATCH C | 1 | 1 |  |  |  | N/A | REBECCA Y | 0 |  |  |  | 2006-11-10 |  |  |  |  |
| 1241010 |  | Conduct N&S Addition Prelim Design & Safety Review |  | 31d | 2006-11-22 A | 2007-01-16 A | 1241005 | 100% |  |  | PLANT ENG [80 h] | 5,003.2 | 5,003.2 | 5003.2 | WHITLATCH C | 1 | 1 |  |  |  | N/A | REBECCA Y | 0 |  |  |  | 2006-12-12 |  |  |  |  |
| 1241040M |  | Begin Design N&S Access Building Utilities (ACCEL) | milestone | 0d | 2006-12-11 A | 2006-12-11 A | 1241010, 1241000M | 100% | 2006-12-13 | 2006-12-13 |  |  |  | 0 | WHITLATCH C | 1 | 1 | 9 |  |  | N/A | REBECCA Y |  |  |  |  | 2006-12-13 |  |  |  |  |
| 1241045 |  | Develop N&S Utilities 35% Design (ACCEL) |  | 87d | 2006-12-11 A | 2007-04-20 A | 1241040M | 100% |  |  | PLANT ENG [240 h]; OFFICE [120 h]; MECH DES [40 h] | 19,831.71 | 19,831.71 | 19876.4 | WHITLATCH C | 1 | 1 |  |  |  | N/A | REBECCA Y | 0 |  |  |  | 2007-02-15 | 09-012 |  |  |  |
| 1241160M |  | Begin Design N&S Linac Power (ACCEL) | milestone | 0d | 2006-12-11 A | 2006-12-11 A | 1241045 | 100% | 2007-02-16 | 2007-02-16 |  |  |  | 0 | WHITLATCH C | 1 | 1 | 9 |  |  | N/A | REBECCA Y |  |  |  |  | 2007-02-16 |  |  |  |  |
| 1241165 |  | Develop N&S Linac 35% Design (ACCEL) |  | 69d | 2006-12-11 A | 2007-03-27 A | 1241160M | 100% |  |  | PLANT ENG [120 h] | 7,504.8 | 7,504.8 | 7504.8 | WHITLATCH C | 1 | 1 |  |  |  | N/A | REBECCA Y | 0 |  |  |  | 2007-03-30 |  |  |  |  |
| 1241080M |  | Begin Design Beam Switch Yard Addition (ACCEL) | milestone | 0d | 2007-02-20 A | 2007-02-20 A | 1241005 | 100% | 2006-11-13 | 2006-11-13 |  |  |  | 0 | WHITLATCH C | 1 | 1 | 9 |  |  | N/A | REBECCA Y |  |  |  |  | 2006-11-13 |  |  |  |  |
| 1241085 |  | Develop BSY Addition 35% Design (ACCEL) |  | 34d | 2007-02-20 A | 2007-04-06 A | 1241080M | 100% |  |  | MECH DES [40 h]; PLANT ENG [360 h] | 24,233.25 | 24,233.25 | 24287.6 | WHITLATCH C | 1 | 1 |  |  |  | N/A | REBECCA Y | 0 |  |  |  | 2007-03-16 | 09-012 |  |  |  |
| 1241170 |  | Conduct N&S Linac 35% Design & Safety Review |  | 34d | 2007-04-03 A | 2007-05-18 A | 1241165 | 100% |  |  | PLANT ENG [40 h] | 2,463.2 | 2,463.2 | 2463.2 | WHITLATCH C | 1 | 1 |  |  |  | N/A | REBECCA Y | 0 |  |  |  | 2007-04-13 |  |  |  |  |
| 1241090 |  | Conduct BSY Addition 35% Design & Safety Review |  | 23d | 2007-04-11 A | 2007-05-11 A | 1241085 | 100% |  |  | PLANT ENG [80 h] | 4,926.4 | 4,926.4 | 4964.8 | WHITLATCH C | 1 | 1 |  |  |  | N/A | REBECCA Y | 0 |  |  |  | 2007-04-13 |  |  |  |  |
| 1241120M |  | Begin Design Tunnel A/C (ACCEL) | milestone | 0d | 2007-04-16 A | 2007-04-16 A | 1241045 | 100% | 2007-02-16 | 2007-02-16 |  |  |  | 0 | WHITLATCH C | 1 | 1 | 9 |  |  | N/A | REBECCA Y |  |  |  |  | 2007-02-16 |  |  |  |  |
| 1241125 |  | Develop Tunnel A/C 35% Design (ACCEL) |  | 30d | 2007-04-16 A | 2007-05-25 A | 1241120M | 100% |  |  | MECH DES [40 h]; PLANT ENG [160 h] | 11,602 | 11,602 | 11720.4 | WHITLATCH C | 1 | 1 |  |  |  | N/A | REBECCA Y | 0 |  |  |  | 2007-04-20 | 09-012 |  |  |  |
| 1241050 |  | Conduct N&S Utilities 35% Design & Safety Review |  | 9d | 2007-04-24 A | 2007-05-04 A | 1241045 | 100% |  |  | PLANT ENG [80 h] | 4,926.4 | 4,926.4 | 4984 | WHITLATCH C | 1 | 1 |  |  |  | N/A | REBECCA Y | 0 |  |  |  | 2007-04-13 |  |  |  |  |
| 1241130 |  | Conduct Tunnel A/C 35% Design & Safety Review |  | 7d | 2007-05-29 A | 2007-06-06 A | 1241125 | 100% |  |  | PLANT ENG [40 h] | 2,463.2 | 2,463.2 | 2463.2 | WHITLATCH C | 1 | 1 |  |  |  | N/A | REBECCA Y | 0 |  |  |  | 2007-05-18 |  |  |  |  |
| 1241015 |  | Conduct N&S Addition Cost Validation (ACCEL) |  | 31d | 2007-06-20 A | 2007-08-02 A | 1241010 | 100% |  |  |  |  |  | 0 | WHITLATCH C | 1 | 1 |  |  |  | N/A | REBECCA Y |  |  |  |  | 2007-01-03 | 09-012 |  |  |  |
| 1241055 |  | Conduct N&S Utilities Cost Validation (ACCEL) |  | 31d | 2007-06-20 A | 2007-08-02 A | 1241050 | 100% |  |  | PLABOR | 3,095 |  | 3095 | WHITLATCH C | 1 | 1 |  |  |  | N/A | REBECCA Y | 0 |  |  |  | 2007-05-11 |  |  |  |  |
| 1241095 |  | Conduct BSY Addition Cost Validation (ACCEL) |  | 31d | 2007-06-20 A | 2007-08-02 A | 1241090 | 100% |  |  | PLABOR | 3,095 |  | 3095 | WHITLATCH C | 1 | 1 |  |  |  | N/A | REBECCA Y | 0 |  |  |  | 2007-05-11 |  |  |  |  |
| 1241135 |  | Conduct Tunnel A/C Cost Validation (ACCEL) |  | 31d | 2007-06-20 A | 2007-08-02 A | 1241130 | 100% |  |  | PLABOR | 3,095 |  | 3095 | WHITLATCH C | 1 | 1 |  |  |  | N/A | REBECCA Y | 0 |  |  |  | 2007-06-04 |  |  |  |  |
| 1241175 |  | Conduct N&S Linac Cost Validation (ACCEL) |  | 31d | 2007-06-20 A | 2007-08-02 A | 1241170 | 100% |  |  | PLABOR | 3,095 |  | 3095 | WHITLATCH C | 1 | 1 |  |  |  | N/A | REBECCA Y | 0 |  |  |  | 2007-04-27 |  |  |  |  |
| 1241020 |  | Develop N&S Addition 100% Dsgn (ACCEL) |  | 89d | 2007-08-01 A | 2007-12-06 A | 9-080M | 100% |  |  | PLABOR; PLANT ENG [280 h]; ELEC ENG [80 h]; MECH ENG [80 h]; MECH DES [40 h]; OFFICE [120 h] | 32,589.3 | 31,526.44 | 33056.057 | WHITLATCH C | 1 | 1 |  |  | 07-027 | N/A | REBECCA Y | 0 |  |  |  |  |  |  |  |  |
| 1241016M |  | N&S Access Building Preliminary Design Complete | milestone | 0d | 2007-08-02 A | 2007-08-02 A | 1241015 | 100% | 2007-09-05 | 2007-09-05 |  |  |  | 0 | WHITLATCH C | 1 | 1 | 5 |  |  | N/A | REBECCA Y |  |  |  |  | 2007-01-03 |  |  |  |  |
| 1241056M |  | N&S Utilities Building Preliminary Design Complete | milestone | 0d | 2007-08-02 A | 2007-08-02 A | 1241055 | 100% | 2007-09-05 | 2007-09-05 |  |  |  | 0 | WHITLATCH C | 1 | 1 | 5 |  |  | N/A | REBECCA Y |  |  |  |  | 2007-05-11 |  |  |  |  |
| 1241096M |  | BSY Addition Preliminary Design Complete (ACCEL) | milestone | 0d | 2007-08-02 A | 2007-08-02 A | 1241095 | 100% | 2007-09-05 | 2007-09-05 |  |  |  | 0 | WHITLATCH C | 1 | 1 | 5 |  |  | N/A | REBECCA Y |  |  |  |  | 2007-05-11 |  |  |  |  |
| 1241136M |  | Tunnel A/C Preliminary Design Complete (ACCEL) | milestone | 0d | 2007-08-02 A | 2007-08-02 A | 1241135 | 100% | 2007-09-05 | 2007-09-05 |  |  |  | 0 | WHITLATCH C | 1 | 1 | 5 |  |  | N/A | REBECCA Y |  |  |  |  | 2007-06-04 |  |  |  |  |
| 1241176M |  | N&S Linac Preliminary Design Complete | milestone | 0d | 2007-08-02 A | 2007-08-02 A | 1241175 | 100% | 2007-09-05 | 2007-09-05 |  |  |  | 0 | WHITLATCH C | 1 | 1 | 5 |  |  | N/A | REBECCA Y |  |  |  |  | 2007-04-27 |  |  |  |  |
| 1241100 |  | Develop BSY Addition 100% Dsgn (ACCEL) |  | 107d | 2007-08-08 A | 2008-01-17 A | 9-080M, 1241025 | 100% |  |  | ELEC ENG [80 h]; MECH ENG [40 h]; MECH DES [40 h]; PLANT ENG [280 h]; PLABOR; OFFICE [120 h] | 31,329.69 | 29,203.98 | 31645.314 | WHITLATCH C | 1 | 1 |  |  | 07-027 | N/A | REBECCA Y | 0 |  |  |  |  |  |  |  |  |
| 1241060 |  | Develop N&S Utilities 100% Dsgn (ACCEL) |  | 123d | 2007-09-04 A | 2008-03-07 A | 9-080M | 100% |  |  | OFFICE [80 h]; MECH DES [40 h]; PLABOR; MECH ENG [360 h]; ELEC ENG [80 h] | 34,006.34 | 30,807.45 | 34154.09 | WHITLATCH C | 1 | 1 |  |  | 07-027 | N/A | REBECCA Y | 0 |  |  |  |  |  |  |  |  |
| 1241025 |  | Conduct N&S Addition 100% Dsgn & Safty Review |  | 8d | 2007-12-19 A | 2008-01-08 A | 1241020 | 100% |  |  | PLANT ENG [80 h] | 4,956 | 4,956 | 4956 | WHITLATCH C | 1 | 1 |  |  | 07-027 | N/A | REBECCA Y | 0 |  |  |  |  |  |  |  |  |
| 1241030 |  | Develop N&S Addition Final Dsgn (ACCEL) |  | 151d | 2008-01-29 A | 2008-08-29 A | 1241025 | 100% |  |  | PLANT ENG [80 h] | 4,956 | 4,956 | 4956 | WHITLATCH C | 1 | 1 |  |  | 07-027 | N/A | REBECCA Y | 0 |  |  |  |  |  |  |  |  |
| 1241105 |  | Conduct BSY Addition 100% Dsgn & Safty Review |  | 9d | 2008-02-01 A | 2008-02-13 A | 1241100 | 100% |  |  | PLANT ENG [40 h] | 2,478 | 2,478 | 2478 | WHITLATCH C | 1 | 1 |  |  | 07-027 | N/A | REBECCA Y | 0 |  |  |  |  |  |  |  |  |
| 1241110 |  | Develop BSY Addition Final Dsgn (ACCEL) |  | 153d | 2008-02-14 A | 2008-09-19 A | 1241105 | 100% |  |  | PLANT ENG [40 h] | 2,478 | 2,478 | 2478 | WHITLATCH C | 1 | 1 |  |  | 07-027 | N/A | REBECCA Y | 0 |  |  |  |  |  |  |  |  |
| 1241065 |  | Conduct N&S Utilities100% Dsgn & Safty Review |  | 32d | 2008-03-10 A | 2008-04-22 A | 1241060 | 100% |  |  | MECH ENG [40 h] | 2,473.6 | 2,473.6 | 2473.6 | WHITLATCH C | 1 | 1 |  |  | 07-027 | H | REBECCA Y | 0 |  |  |  |  |  |  |  |  |
| 1241140 |  | Develop Tunnel A/C 100% Dsgn (ACCEL) |  | 87d | 2008-03-17 A | 2008-07-18 A | 9-080M, 1241060 FS-5d | 100% | 2008-03-17 | 2008-07-17 | MECH ENG [200 h]; OFFICE [40 h]; PLABOR; ELEC ENG [80 h] | 20,480.11 | 18,354.4 | 20480.114 | WHITLATCH C | 1 | 1 |  |  | 07-027 | N/A | REBECCA Y | 0 |  |  |  |  |  |  |  |  |
| 1241180 |  | Develop N&S Linac 100% Dsgn (ACCEL) |  | 54d | 2008-03-17 A | 2008-05-30 A | 9-080M FS+80d | 100% |  |  | PLABOR; ELEC ENG [240 h]; OFFICE [40 h]; MECH DES [40 h] | 18,717.18 | 17,644 | 18717.176 | WHITLATCH C | 1 | 1 |  |  | 07-027 | H | REBECCA Y | 0 |  |  |  |  |  |  |  |  |
| 1241070 |  | Develop N&S Utilities Final Dsgn (ACCEL) |  | 97d | 2008-05-12 A | 2008-09-26 A | 1241065 | 100% |  |  | MECH ENG [40 h] | 2,473.6 | 2,473.6 | 2473.6 | WHITLATCH C | 1 | 1 |  |  | 07-027 | H | REBECCA Y | 0 |  |  |  |  |  |  |  |  |
| 1241185 |  | Conduct N&S Linac 100% Dsgn & Safty Review |  | 18d | 2008-06-05 A | 2008-07-01 A | 1241180 | 100% | 2008-06-05 | 2008-06-30 | ELEC ENG [40 h] | 2,489.6 | 2,489.6 | 2489.6 | WHITLATCH C | 1 | 1 |  |  | 07-027 | H | REBECCA Y | 0 |  |  |  |  |  |  |  |  |
| 1241190 |  | Develop N&S Linac Final Dsgn (ACCEL) |  | 35d | 2008-07-02 A | 2008-08-20 A | 1241185 | 100% |  |  | ELEC ENG [40 h] | 2,489.6 | 2,489.6 | 2489.6 | WHITLATCH C | 1 | 1 |  |  | 07-027 | H | REBECCA Y | 0 |  |  |  |  |  |  |  |  |
| 1241145 |  | Conduct Tunnel A/C 100% Dsgn & Safty Review |  | 12d | 2008-08-04 A | 2008-08-19 A | 1241140 | 100% |  |  | MECH ENG [40 h] | 2,473.6 | 2,473.6 | 2473.6 | WHITLATCH C | 1 | 1 |  |  | 07-027 | H | REBECCA Y | 0 |  |  |  |  |  |  |  |  |
| 1241150 |  | Develop Tunnel A/C Final Dsgn (ACCEL) |  | 20d | 2008-08-20 A | 2008-09-17 A | 1241145 | 100% |  |  | MECH ENG [40 h] | 2,473.6 | 2,473.6 | 2473.6 | WHITLATCH C | 1 | 1 |  |  | 07-027 | H | REBECCA Y | 0 |  |  |  |  |  |  |  |  |
| 1241195M |  | Comp Dsgn N&S Linac Pwr (ACCEL)++ | milestone | 0d | 2008-08-20 A | 2008-08-20 A | 1241190 | 100% | 2008-09-16 | 2008-09-16 |  |  |  | 0 | WHITLATCH C | 1 | 1 | 6 |  | 07-027 | M | REBECCA Y |  |  |  |  |  |  |  |  |  |
| 1241035M |  | Comp Dsgn N&S Access Bldng Addition+ | milestone | 0d | 2008-08-29 A | 2008-08-29 A | 1241030 | 100% | 2008-09-16 | 2008-09-16 |  |  |  | 0 | WHITLATCH C | 1 | 1 | 6 |  | 07-027 | M | REBECCA Y |  |  |  |  |  |  |  |  |  |
| 1241155M |  | Comp Dsgn Tunnel A/C (ACCEL)+ | milestone | 0d | 2008-09-17 A | 2008-09-17 A | 1241150 | 100% | 2008-10-20 | 2008-10-20 |  |  |  | 0 | WHITLATCH C | 1 | 1 | 6 |  | 07-027 | M | REBECCA Y |  |  |  |  |  |  |  |  |  |
| 1241115M |  | Comp Dsgn Beam Switch Yard Addition | milestone | 0d | 2008-09-19 A | 2008-09-19 A | 1241110 | 100% | 2008-10-13 | 2008-10-13 |  |  |  | 0 | WHITLATCH C | 1 | 1 | 6 |  | 07-027 | M | REBECCA Y |  |  |  |  |  |  |  |  |  |
| 1241075M |  | Comp Dsgn N&S Utilities (ACCEL)+ | milestone | 0d | 2008-09-26 A | 2008-09-26 A | 1241070 | 100% | 2008-10-27 | 2008-10-27 |  |  |  | 0 | WHITLATCH C | 1 | 1 | 6 |  | 07-027 | M | REBECCA Y |  |  |  |  |  |  |  |  |  |
| 1241200 |  | Re-Baseline Actuals Adjustment |  | 1d | 2013-08-30 A | 2013-08-30 A |  | 100% | 2013-09-03 | 2013-09-03 | PROCUREMENT>$50K 69 NO ESCALATION | 119,529.34 |  | 119529.34 |  |  |  |  |  |  |  |  |  |  | 100 | ADJ |  |  | 0 | 119529.34 | 11952934 |

| ID | WBS | Activity | Type | Duration | Start | Finish | Predecessors | Complete | Planned start | Planned finish | Resources | Cost | Actual cost | Planned FinishUDF | MONTHLY EV COST | RESP - Responsibility | STRT%COMP for CM EVM | FNSH%COMP for CM EVM | EVMS Reporting Codes | CAM RESPONSIBLE | Calculated Remaining Total Cost | Milestone Level | Remaining Material Cost Based on % Compl | Claimed Material Cost Based on % Complet | Initial Claimed Material Calc | Claimed Material Divider | CR 08-058 | ReBaseline Actuals Adjustment | CR 07-018 | CR 07-021 | CR 09-012 | CR 07-027 | CR 08-017 | EXPNS ACT BRIDGING FY SPLIT | CR 09-001 | CR 10-042 | CR 10-061 | CR 08-026 |
| --- | --- | --- | --- | --- | --- | --- | --- | --- | --- | --- | --- | --- | --- | --- | --- | --- | --- | --- | --- | --- | --- | --- | --- | --- | --- | --- | --- | --- | --- | --- | --- | --- | --- | --- | --- | --- | --- | --- |
|  | 2 | **1.2.4.2 CHL** |  |  | 2006-10-02 | 2013-08-30 |  |  |  |  |  |  |  |  |  |  |  |  |  |  |  |  |  |  |  |  |  |  |  |  |  |  |  |  |  |  |  |  |
| 1242005M |  | Begin Design CHL Addition (CHL) | milestone | 0d | 2006-10-02 A | 2006-10-02 A | 9-070M | 100% |  |  |  |  |  | 2006-10-02 | 0 | YASKY R | 1 | 1 | N/A | REBECCA Y |  |  |  |  |  |  |  |  |  |  |  |  |  |  |  |  |  |  |
| 1242010 |  | Develop CHL 60% Design (CHL) |  | 39d | 2006-10-02 A | 2006-11-27 A | 1242005M | 100% |  |  |  |  |  | 2006-11-28 | 0 | YASKY R | 1 | 1 | N/A | REBECCA Y |  |  |  |  |  |  |  |  |  |  |  |  |  |  |  |  |  |  |
| 1242015 |  | Conduct CHL 60% Design & Safety Review |  | 32d | 2006-11-28 A | 2007-01-19 A | 1242010 | 100% |  |  | PLANT ENG [240 h] | 15,009.6 | 15,009.6 | 2006-12-19 | 15009.6 | YASKY R | 1 | 1 | N/A | REBECCA Y | 0 |  |  |  |  |  |  |  |  |  |  |  |  |  |  |  |  |  |
| 1242015M |  | 60% Design CHL Complete | milestone | 0d | 2006-12-19 A | 2006-12-19 A | 1242015 | 100% |  |  |  |  |  | 2006-12-19 | 0 | YASKY R | 1 | 1 | N/A | REBECCA Y |  | 5 |  |  |  |  |  |  |  |  |  |  |  |  |  |  |  |  |
| 1242020 |  | Develop CHL 100% Design (CHL) |  | 58d | 2007-02-20 A | 2007-05-10 A | 1242015M | 100% |  |  | PROCUREMENT>$50K 69; PROCUREMENT<$50K 60 | 61,920 |  | 2007-03-02 | 61920 | YASKY R | 1 | 1 | N/A | REBECCA Y | 0 |  | 0 | 61920 | 6192000 | 100 |  |  |  |  |  |  |  |  |  |  |  |  |
| 1242025 |  | Conduct CHL 100% Design & Safety Review |  | 34d | 2007-06-18 A | 2007-08-03 A | 1242020 | 100% |  |  | PLANT ENG [480 h] | 29,035.09 | 29,035.09 | 2007-03-30 | 30019.2 | YASKY R | 1 | 1 | N/A | REBECCA Y | 0 |  |  |  |  |  |  |  |  |  |  |  |  |  |  |  |  |  |
| 1242025M |  | 100% Design CHL Complete | milestone | 0d | 2007-08-03 A | 2007-08-03 A | 1242025 | 100% | 2007-09-06 | 2007-09-06 |  |  |  | 2007-03-30 | 0 | YASKY R | 1 | 1 | N/A | REBECCA Y |  | 5 |  |  |  |  |  |  |  |  |  |  |  |  |  |  |  |  |
| 1242030 |  | Develop CHL Final Design (CHL) |  | 32d | 2007-09-10 A | 2007-10-23 A | 1242025M | 100% |  |  | PROCUREMENT>$50K 69 | 20,640 |  | 2007-04-13 | 20640 | YASKY R | 1 | 1 | N/A | REBECCA Y | 0 |  | 0 | 20640 | 2064000 | 100 |  |  |  |  |  |  |  |  |  |  |  |  |
| 1242035 |  | Conduct CHL Final Design & Safety Review |  | 8d | 2007-11-26 A | 2007-12-05 A | 1242030 | 100% |  |  | PLANT ENG [80 h]; OFFICE [40 h] | 5,963.2 | 5,963.2 | 2007-04-27 | 5956 | YASKY R | 1 | 1 | N/A | REBECCA Y | 0 |  |  |  |  |  |  |  |  |  |  |  |  |  |  |  |  |  |
| 1242040M |  | Complete Design CHL Addition (CHL) | milestone | 0d | 2008-04-25 A | 2008-04-25 A | 1242035 FS+95d | 100% | 2008-05-01 | 2008-05-01 |  |  |  | 2007-04-27 | 0 | YASKY R | 1 | 1 | M | REBECCA Y |  | 5 |  |  |  |  |  |  |  |  |  |  |  |  |  |  |  |  |
| 1621000MX |  | CHL Addition Begin Proc Prep | milestone | 0d | 2008-10-01 A | 2008-10-01 A | 9-090M | 100% |  |  |  |  |  |  | 0 | CHANDRA S | 1 | 1 | M | REBECCA Y |  | 6 |  |  |  |  | 08-058 |  |  |  |  |  |  |  |  |  |  |  |
| 1621005X |  | Prcrmnt Prep for CHL Addition to Award Contract |  | 51d | 2008-10-01 A | 2008-12-12 A | 1621000MX | 100% |  |  | PLANT ENG [67.43 h] | 4,310.8 | 4,310.8 |  | 4310.7999 | CHANDRA S | 1 | 1 | H | REBECCA Y | 0 |  |  |  |  |  | 08-058 |  |  |  |  |  |  |  |  |  |  |  |
| 1242045 |  | Re-Baseline Actuals Adjustment |  | 1d | 2013-08-30 A | 2013-08-30 A |  | 100% | 2013-09-03 | 2013-09-03 | PROCUREMENT>$50K 69 NO ESCALATION | -28,129.35 |  |  |  |  |  |  |  |  |  |  |  |  |  | 100 |  | ADJ |  |  |  |  |  |  |  |  |  |  |
|  | 3 | **1.2.4.3 HALL D** |  |  | 2006-10-02 | 2013-08-30 |  |  |  |  |  |  |  |  |  |  |  |  |  |  |  |  |  |  |  |  |  |  |  |  |  |  |  |  |  |  |  |  |
| 1243005M |  | Begin Definitive Design Hall D Complex | milestone | 0d | 2006-10-02 A | 2006-10-02 A | 9-070M | 100% |  |  |  |  |  | 2006-10-02 | 0 | YASKY R | 1 | 1 | N/A | REBECCA Y |  |  |  |  |  |  |  |  |  |  |  |  |  |  |  |  |  |  |
| 1243010 |  | Develop Hall D 60% Design (HALL D) |  | 44d | 2006-10-13 A | 2006-12-15 A | 1243005M | 100% |  |  | PROCUREMENT>$50K 69; PROCUREMENT<$50K 60 | 69,712 |  | 2006-12-05 | 69712 | YASKY R | 1 | 1 | N/A | REBECCA Y | 0 |  | 0 | 69712 | 6971200 | 100 |  |  |  |  |  |  |  |  |  |  |  |  |
| 1243015 |  | Conduct Hall D 60% Design & Safety Review |  | 34d | 2006-12-21 A | 2007-02-15 A | 1243010 | 100% |  |  | PLANT ENG [1000 h]; OFFICE [120 h] | 65,633.6 | 65,633.6 | 2007-01-18 | 65633.6 | YASKY R | 1 | 1 | N/A | REBECCA Y | 0 |  |  |  |  |  |  |  |  |  |  |  |  |  |  |  |  |  |
| 1243015M |  | 60% Design Hall D Complete | milestone | 0d | 2007-02-15 A | 2007-02-15 A | 1243015 | 100% | 2007-01-18 | 2007-01-18 |  |  |  | 2007-01-18 | 0 | YASKY R | 1 | 1 | N/A | REBECCA Y |  | 5 |  |  |  |  |  |  |  |  |  |  |  |  |  |  |  |  |
| 1243018 |  | Independent Cost Validation |  | 39d | 2007-04-24 A | 2007-06-18 A | 1243015M FS+65d | 100% |  |  | PROCUREMENT<$50K 60 | 37,000 |  | 2007-01-18 | 37000 | YASKY R | 1 | 1 | N/A | REBECCA Y | 0 |  | 0 | 37000 | 3700000 | 100 |  |  | 07-018 |  |  |  |  |  |  |  |  |  |
| 1243021 |  | Develop Hall D Civil Commissioning Plan |  | 255d | 2007-05-14 A | 2008-05-22 A | 1243015M FS+85d | 100% |  |  | PROCUREMENT<$50K 60 | 20,000 |  | 2007-01-18 | 20000 | YASKY R | 1 | 1 | N/A | REBECCA Y | 0 |  | 0 | 20000 | 2000000 | 100 |  |  | 07-018 |  |  |  |  |  |  |  |  |  |
| 1243020 |  | Develop Hall D 100% Design (HALL D) |  | 78d | 2007-06-18 A | 2007-10-05 A | 1243015M FS+85d | 100% |  |  | PROCUREMENT<$50K 60 | 80,000 |  | 2007-04-13 | 80000 | YASKY R | 1 | 1 | N/A | REBECCA Y | 0 |  | 0 | 80000 | 8000000 | 100 |  |  | 07-018 | 07-021 | 09-012 |  |  |  |  |  |  |  |
| 1243025 |  | Conduct Hall D 100% Design & Safety Review |  | 30d | 2007-10-11 A | 2007-11-21 A | 1243021, 1243020 | 100% |  |  | PROCUREMENT<$50K 60 NO ESCALATION FY08; PLANT ENG [680 h] | 78,126 | 42,126 | 2007-05-25 | 77084.512 | YASKY R | 1 | 1 | N/A | REBECCA Y | 0 |  | 0 | 36000 | 3600000 | 100 |  |  | 07-018 |  | 09-012 | 07-027 | 08-017 |  |  |  |  |  |
| 1243025M |  | 100% Design Hall D Complete | milestone | 0d | 2007-11-21 A | 2007-11-21 A | 1243018, 1243025 | 100% | 2008-02-21 | 2008-02-21 |  |  |  | 2007-05-25 | 0 | YASKY R | 1 | 1 | N/A | REBECCA Y |  | 5 |  |  |  |  |  |  | 07-018 |  |  | 07-027 |  |  |  |  |  |  |
| 1243030 |  | Develop Hall D Final Design (HALL D) |  | 22d | 2008-01-02 A | 2008-02-01 A | 1243025M | 100% |  |  | PROCUREMENT>$50K 69 | 68,154.93 |  | 2007-06-18 | 68154.9312 | YASKY R | 1 | 1 | N/A | REBECCA Y | 0 |  | 0 | 68154.93 | 6815493 | 100 |  |  | 07-018 |  |  | 07-027 |  |  |  |  |  |  |
| 1243035 |  | Conduct Hall D Final Design & Safety Review |  | 21d | 2008-02-05 A | 2008-03-05 A | 1243030 FS-5d | 100% |  |  | PLANT ENG [240 h] | 14,868 | 14,868 | 2007-07-02 | 14868 | YASKY R | 1 | 1 | N/A | REBECCA Y | 0 |  |  |  |  |  |  |  | 07-018 |  | 09-012 | 07-027 |  |  |  |  |  |  |
| 1243040M |  | Complete Design Hall D Complete (HALL D) | milestone | 0d | 2008-03-05 A | 2008-03-05 A | 1243035 FS+10d | 100% | 2008-04-16 | 2008-04-16 |  |  |  | 2007-07-02 | 0 | YASKY R | 1 | 1 | N/A | REBECCA Y |  | 5 |  |  |  |  |  |  | 07-018 |  |  | 07-027 | 08-017 |  |  |  |  |  |
| 1243050 |  | PROC Procurement Prep to Award Hall D Contract |  | 210d | 2008-03-06 A | 2009-01-08 A | 1243040M FS+15d | 100% |  |  | PROCUREMENT<$50K 60 NO ESCALATION FY09 | 25,797.5 |  | 2007-07-02 | 25797.5 | YASKY R | 1 | 1 | N/A | REBECCA Y | 0 |  | 0 | 25797.5 | 2579750 | 100 |  |  |  |  | 09-012 | 07-027 | 08-017 | EXP0809 | 09-001 | 10-042 | 10-061 |  |
| 1243050a |  | FY08 LAB/EXP Procurement Prep to Award Hall D Contract |  | 187d | 2008-03-06 A | 2008-11-26 A | 1243040M FS+15d | 100% |  |  | ELEC ENG [233.85 h]; MECH ENG [272.82 h]; PLANT ENG [38.97 h] | 34,077 | 34,077 | 2007-07-02 | 33840.2043 | YASKY R | 1 | 1 | N/A | REBECCA Y | 0 |  |  |  |  |  |  |  |  |  | 09-012 | 07-027 | 08-017 | EXP0809 | 09-001 | 10-042 | 10-061 |  |
| 1243055 |  | Hall D Survey Network |  | 89d | 2008-05-19 A | 2008-09-23 A | 1243040M | 100% |  |  | MECH ENG [80 h]; MECH TECH [200 h]; PROCUREMENT<$50K 60 | 18,787.2 | 12,787.2 | 2007-07-02 | 18787.2 | YASKY R | 1 | 1 | C | REBECCA Y | 0 |  | 0 | 6000 | 600000 | 100 |  |  |  |  |  |  |  |  |  | 10-042 | 10-061 | 08-026 |
| 1243045 |  | Obtain Permit to Dispose of Dewater Effleuent (HALL D)+ |  | 177d | 2008-05-28 A | 2009-02-13 A | 1243035 FS+55d | 100% |  |  | PLANT ENG [160 h]; PROCUREMENT<$50K 60 | 41,028.29 | 10,071.29 | 2007-07-02 | 40869 | YASKY R | 1 | 1 | H | REBECCA Y | 0 |  | 0 | 30957 | 3095700 | 100 |  |  |  |  |  | 07-027 |  |  |  | 10-042 | 10-061 |  |
| 1243050b |  | FY09 LAB/EXP Procurement Prep to Award Hall D Contract |  | 23d | 2008-12-01 A | 2009-01-08 A | 1243050a | 100% |  |  | PLANT ENG [1.03 h]; ELEC ENG [6.15 h]; MECH ENG [7.18 h] | 919.02 | 919.02 | 2007-07-02 | 919.0182 | YASKY R | 1 | 1 | N/A | REBECCA Y | 0 |  |  |  |  |  |  |  |  |  | 09-012 | 07-027 | 08-017 | EXP0809 | 09-001 | 10-042 | 10-061 |  |
| 1243060 |  | Re-Baseline Actuals Adjustment |  | 1d | 2013-08-30 A | 2013-08-30 A |  | 100% | 2013-09-03 | 2013-09-03 | PROCUREMENT>$50K 69 NO ESCALATION | 60,649.89 |  |  | 60649.89 |  |  |  |  |  |  |  | 0 | 60649.89 | 6064989 | 100 |  | ADJ |  |  |  |  |  |  |  |  |  |  |

Notes:
- 1621000MX: Entry Criteria: Predecessor 1242040M (CHL Design / Completed)

| ID | WBS | Activity | Type | Duration | Start | Finish | Predecessors | Complete | Planned start | Planned finish | Resources | Cost | Actual cost | Planned FinishUDF | Calculated Remaining Total Cost | MONTHLY EV COST | RESP - Responsibility | Special | STRT%COMP for CM EVM | FNSH%COMP for CM EVM | EVMS Reporting Codes | CAM RESPONSIBLE | LOE Divider | LOE Multiplier | CR 09-012 | CR 08-032 | CR 08-058 | Claimed Material Divider | ReBaseline Actuals Adjustment | CR 07-024 | Milestone Level | CR 07-027 | ACT BRIDGING FY SPLIT |
| --- | --- | --- | --- | --- | --- | --- | --- | --- | --- | --- | --- | --- | --- | --- | --- | --- | --- | --- | --- | --- | --- | --- | --- | --- | --- | --- | --- | --- | --- | --- | --- | --- | --- |
|  | 5 | **1.2.5 PROJECT MANAGEMENT** |  |  | 2006-10-02 | 2013-08-30 |  |  |  |  |  |  |  |  |  |  |  |  |  |  |  |  |  |  |  |  |  |  |  |  |  |  |  |
|  | 1 | **1.2.5.1 PED PROJECT MANAGEMENT PROJECT OFFICE (DIR, PM, APM'S)** |  |  | 2006-10-02 | 2013-08-30 |  |  |  |  |  |  |  |  |  |  |  |  |  |  |  |  |  |  |  |  |  |  |  |  |  |  |  |
| 1251006RKC |  | FY06 Obligations RKC |  | 79d | 2006-10-02 A | 2007-01-31 A | 9-070M | 100% |  |  | PLABOR | 6,143.5 |  | 2007-03-30 | 0 | 6143.5 | PARKINSON J | LR | 1 | 1 | N/A | CLAUS R |  |  |  |  |  |  |  |  |  |  |  |
| 1251007LOE |  | FY07 Project Management Project Office |  | 247d | 2006-10-02 A | 2007-09-28 A | 9-070M | 100% |  |  | SR STAFF [4400 h]; ADMIN [880 h]; DIRECTORATE [720 h]; SCIENTIST [880 h]; ELEC ENG [2640 h]; SUPPLIES & MATERIALS | 914,700.08 | 824,920.08 | 2007-09-28 | 0 | 914700.082623 | RODE C |  | 1 | 1 | N/A | CLAUS R | 100 | 100 | 09-012 |  |  |  |  |  |  |  |  |
| 1251908LOE |  | FY08 PED Proj Office Proj Mngmnt P-1 |  | 142d | 2007-10-01 A | 2008-04-30 A | 1251007LOE | 100% |  |  | SR STAFF [3728.8 h]; DIRECTORATE [412.4 h]; OFFICE [504 h]; ELEC ENG [664 h]; SUPPLIES & MATERIALS; SCIENTIST [366.4 h]; MECH ENG [297.6 h]; ADMIN [504 h] | 629,498.41 | 566,781.44 |  | 0 | 629473.4673 | RODE C |  | 1 | 1 | N/A | CLAUS R | 100 | 100 |  | 08-032 |  |  |  |  |  |  |  |
| 1251908LOEB |  | FY08 PED Proj Office Proj Mngmnt P-2 |  | 106d | 2008-05-01 A | 2008-09-30 A | 1251908LOE | 100% |  |  | SCIENTIST [273.55 h]; ADMIN [376.13 h]; SR STAFF [1745.16 h]; OFFICE [376.13 h]; ELEC ENG [495.81 h]; SUPPLIES & MATERIALS; MECH ENG [222.26 h] | 314,583.31 | 264,514.86 |  | 0 | 314583.3143 | RODE C |  | 1 | 1 | E | CLAUS R | 100 | 100 | 09-012 | 08-032 |  |  |  |  |  |  |  |
| 171909LOEX |  | FY09 Constrctn Proj Office Proj Mngmnt |  | 59d | 2008-10-01 A | 2008-12-24 A | 1252908LOEB | 100% |  |  | SUPPLIES & MATERIALS; DIRECTORATE [171.29 h]; SCIENTIST [209.35 h]; SR STAFF [1674.84 h]; ADMIN [418.71 h]; ELEC ENG [837.42 h]; OFFICE [418.71 h] | 331,269.93 | 302,512.64 |  | 0 | 331269.914751 | PARKINSON J |  | 1 | 1 | E | CLAUS R | 100 | 100 |  |  | 08-058 |  |  |  |  |  |  |
| 1251910 |  | Re-Baseline Actuals Adjustment |  | 1d | 2013-08-30 A | 2013-08-30 A |  | 100% | 2013-09-03 | 2013-09-03 | PROCUREMENT>$50K 69 NO ESCALATION | -258,656.11 |  |  |  |  |  |  |  |  |  |  |  |  |  |  |  | 100 | ADJ |  |  |  |  |
|  | 2 | **1.2.5.2 PED PROJECT MANAGEMENT PROJECT OFFICE (OPM STAFF)** |  |  | 2006-10-02 | 2013-08-30 |  |  |  |  |  |  |  |  |  |  |  |  |  |  |  |  |  |  |  |  |  |  |  |  |  |  |  |
| 1252007LOE |  | FY07 Project Management Project Office |  | 247d | 2006-10-02 A | 2007-09-28 A | 9-070M | 100% |  |  | SR STAFF [528 h]; ADMIN [1056 h]; SUPPLIES & MATERIALS; MECH ENG [1056 h] | 216,710 | 172,330 | 2007-09-28 | 0 | 216709.99805 | RODE C |  | 1 | 1 | N/A | CLAUS R | 100 | 100 | 09-012 |  |  |  |  |  |  |  |  |
| 1252010 |  | PREP for OECM EVMS Contractor Certification Review |  | 43d | 2007-10-01 A | 2007-11-30 A | 3R-07M | 100% |  |  |  |  |  |  |  | 0 | RODE C |  | 1 | 1 | N/A | CLAUS R |  |  |  |  |  |  |  | 07-024 |  |  |  |
| 1252908LOE |  | FY08 PED OPM Proj Mngmnt P-1 |  | 130d | 2007-10-01 A | 2008-04-15 A | 1252007LOE, 122211007LOE | 100% | 2007-10-01 | 2008-04-14 | ADMIN [1115.6 h]; SUPPLIES & MATERIALS; OFFICE [380.4 h]; DIRECTORATE [278.8 h]; MECH ENG [1394.4 h] | 231,498.64 | 200,560.11 |  | 0 | 231521.4074 | PARKINSON J |  | 1 | 1 | N/A | CLAUS R | 100 | 100 |  | 08-032 |  |  |  |  |  |  |  |
| 1252015 |  | OECM EVMS Contractor Certification REVIEW |  | 5d | 2007-12-03 A | 2007-12-07 A | 1252010 FS+3d | 100% |  |  |  |  |  |  |  | 0 | RODE C |  | 1 | 1 | N/A | CLAUS R |  |  |  |  |  |  |  | 07-024 |  |  |  |
| 1252908LOEB |  | FY08 PED OPM Proj Mngmnt P-2 |  | 117d | 2008-04-16 A | 2008-09-30 A | 1252908LOE | 100% |  |  |  |  |  |  |  | 0 | PARKINSON J |  | 1 | 1 | E | CLAUS R | 100 | 100 | 09-012 | 08-032 |  |  |  |  |  |  |  |
| 1252910 |  | Re-Baseline Actuals Adjustment |  | 1d | 2013-08-30 A | 2013-08-30 A |  | 100% | 2013-09-03 | 2013-09-03 | PROCUREMENT>$50K 69 NO ESCALATION | -43,750.29 |  |  |  |  |  |  |  |  |  |  |  |  |  |  |  | 100 | ADJ |  |  |  |  |
|  | 6 | **1.2.6 ACCELERATOR SYSTEMS COMMISSIONING PLANNING** |  |  | 2007-02-23 | 2013-08-30 |  |  |  |  |  |  |  |  |  |  |  |  |  |  |  |  |  |  |  |  |  |  |  |  |  |  |  |
| 126000M |  | Start Milestone for Commissioning PED (ACC SYS COMMIS PLNNG) | milestone | 0d | 2007-02-23 A | 2007-02-23 A | 9-070M FS+22d | 100% | 2006-11-01 | 2006-11-01 |  |  |  | 2006-11-01 |  | 0 | SPATA M |  | 1 | 1 | N/A | MIKE S |  |  |  |  |  |  |  |  | 9 |  |  |
| 126005 |  | Develop draft commissioning plan for EIR (ACC SYS COMMIS PLNNG) |  | 60d | 2007-02-23 A | 2007-05-17 A | 126000M | 100% |  |  | SCIENTIST [139.2 h] | 8,883.98 | 8,883.98 | 2007-05-15 | 0 | 8912.976 | SPATA M |  | 1 | 1 | N/A | MIKE S |  |  |  |  |  |  |  |  |  |  |  |
| 126010 |  | Preliminary Design & Safety Review for Commissioning Plan (ACC SYS COMMIS PLNNG) |  | 1d | 2007-05-18 A | 2007-05-18 A | 126005 | 100% |  |  | SCIENTIST [354.96 h] | 22,553.9 | 22,553.9 | 2007-05-16 | 0 | 22553.90424 | SPATA M |  | 1 | 1 | N/A | MIKE S |  |  |  |  |  |  |  |  |  |  |  |
| 126015 |  | Post-review development of Commissioning Plan (ACC SYS COMMIS PLNNG) |  | 46d | 2007-07-23 A | 2007-09-25 A | 126010 | 100% |  |  | SCIENTIST [27.84 h] | 1,680 | 1,680 | 2007-05-31 | 0 | 1768.9536 | SPATA M |  | 1 | 1 | N/A | MIKE S |  |  |  |  |  |  |  |  |  |  |  |
| 126020M |  | Draft commissioning plan ready for EIR (ACC SYS COMMIS PLNNG) | milestone | 0d | 2007-09-25 A | 2007-09-25 A | 126015 | 100% | 2007-10-25 | 2007-10-25 |  |  |  | 2007-05-31 |  | 0 | SPATA M |  | 1 | 1 | N/A | MIKE S |  |  |  |  |  |  |  |  | 5 |  |  |
| 126025M |  | Start of FY08 Commssng Planning (ACC SYS COMMIS PLNNG) | milestone | 0d | 2008-02-01 A | 2008-02-01 A | 126020M, 9-080M FS+117d | 100% | 2008-03-27 | 2008-03-27 |  |  |  |  |  | 0 | SPATA M |  | 1 | 1 | N/A | MIKE S |  |  |  |  |  |  |  |  | 6 | 07-027 |  |
| 126030 |  | Development of Sys's Cmmssng Milestones (ACC SYS COMMIS PLNNG) |  | 322d | 2008-02-01 A | 2009-05-15 A | 126025M | 100% |  |  | MECH ENG [20 h]; COMP SCIENT [80 h]; ELEC ENG [20 h]; ADMIN [80 h]; SCIENTIST [240 h] | 26,597.22 | 26,597.22 |  | 0 | 26200 | SPATA M |  | 1 | 1 | N/A | MIKE S |  |  |  |  |  |  |  |  |  | 07-027 |  |
| 126060 |  | Development of Beam-Based Cmmssng Plan (ACC SYS COMMIS PLNNG) |  | 142d | 2009-03-03 A | 2009-09-21 A | 126045 FS-10d | 100% |  |  | SCIENTIST [480 h]; ADMIN [200 h] | 41,534.8 | 41,534.8 |  | 0 | 41534.8 | SPATA M |  | 1 | 1 | H | MIKE S |  |  |  |  |  |  |  |  |  | 07-027 | FY08-09 |
| 126040 |  | Review of Sys Milestones with Sys owners (ACC SYS COMMIS PLNNG) |  | 35d | 2009-05-11 A | 2009-06-29 A | 126035M | 100% |  |  | SCIENTIST [20 h]; MECH ENG [20 h]; ELEC ENG [20 h]; ADMIN [20 h] | 4,915 | 4,915 |  | 0 | 4763 | SPATA M |  | 1 | 1 | H | MIKE S |  |  |  |  |  |  |  |  |  | 07-027 |  |
| 126035M |  | Comp Draft Sys's Cmmssng Milestones (ACC SYS COMMIS PLNNG) | milestone | 0d | 2009-05-15 A | 2009-05-15 A | 126030 | 100% | 2009-06-26 | 2009-06-26 |  |  |  |  |  | 0 | SPATA M |  | 1 | 1 | M | MIKE S |  |  |  |  |  |  |  |  | 6 | 07-027 |  |
| 126045 |  | Incorporate Changes from Review of Sys's Milestones (ACC SYS COMMIS PLNNG) |  | 39d | 2009-06-02 A | 2009-07-27 A | 126040 | 100% |  |  | ADMIN [40 h]; SCIENTIST [120 h] | 9,849.2 | 9,849.2 |  | 0 | 9849.2 | SPATA M |  | 1 | 1 | H | MIKE S |  |  |  |  |  |  |  |  |  | 07-027 |  |
| 126065M |  | Comp Draft Beam-Based Commssng Plan (ACC SYS COMMIS PLNNG) | milestone | 0d | 2009-09-21 A | 2009-09-21 A | 126060 | 100% | 2009-10-21 | 2009-10-21 |  |  |  |  |  | 0 | SPATA M |  | 1 | 1 | M | MIKE S |  |  |  |  |  |  |  |  | 6 | 07-027 |  |
| 126070 |  | Review of Beam-Based Cmmssng Plan (ACC SYS COMMIS PLNNG) |  | 1d | 2009-09-22 A | 2009-09-22 A | 126065M | 100% |  |  | SCIENTIST [20 h]; MECH ENG [4 h]; ADMIN [4 h]; ELEC ENG [4 h] | 2,011.16 | 2,011.16 |  | 0 | 2011.16 | SPATA M |  | 1 | 1 | H | MIKE S |  |  |  |  |  |  |  |  |  | 07-027 |  |
| 126075 |  | Incorporate Changes from Review of Beam-Based Plan (ACC SYS COMMIS PLNNG) |  | 5d | 2009-09-23 A | 2009-09-29 A | 126070 | 100% |  |  | ADMIN [40 h]; SCIENTIST [120 h] | 9,849.2 | 9,849.2 |  | 0 | 9849.2 | SPATA M |  | 1 | 1 | H | MIKE S |  |  |  |  |  |  |  |  |  | 07-027 |  |
| 126080M |  | Comp Commssng Plan (ACC SYS COMMIS PLNNG) | milestone | 0d | 2009-09-29 A | 2009-09-29 A | 126075 | 100% | 2009-10-29 | 2009-10-29 |  |  |  |  |  | 0 | SPATA M |  | 1 | 1 | M | MIKE S |  |  |  |  |  |  |  |  | 6 | 07-027 |  |
| 126085 |  | Re-Baseline Actuals Adjustment |  | 1d | 2013-08-30 A | 2013-08-30 A |  | 100% | 2013-09-03 | 2013-09-03 | PROCUREMENT>$50K 69 NO ESCALATION | -69,124.86 |  |  |  |  |  |  |  |  |  |  |  |  |  |  |  | 100 | ADJ |  |  |  |  |

Notes:
- 126060: Explanation: Added (-2) weeks of float 30April2009.

| ID | WBS | Activity | Duration | Start | Finish | Predecessors | Complete | Planned start | Planned finish | Resources | Cost | Actual cost | Calculated Remaining Total Cost | MONTHLY EV COST | RESP - Responsibility | STRT%COMP for CM EVM | FNSH%COMP for CM EVM | EVMS Reporting Codes | CAM RESPONSIBLE | CR 08-050 | CR 10-027 | CR 10-064 | CR 11-051 | CR 12-018 | Advance Purchase Plan > 500K | 12 GEV MAJOR PROCUREMENT CATAGORY | Activities with Steps | CR 09-032 | CR 09-032 Repair | CR 09-012 | Remaining Material Cost Based on % Compl | Claimed Material Cost Based on % Complet | Initial Claimed Material Calc | Claimed Material Divider | CR 09-037 | CR 10-001 | CR 07-027 | CR 08-016 | LOE Divider | LOE Multiplier | CR 10-043 | ReBaseline Actuals Adjustment | CR 09-039 | CR 10-023 | CR 11-003 | CR 11-012 | CR 09-017 | CR 07-024 | LOE % Pre Calc | LOE % | CR 11-001 |
| --- | --- | --- | --- | --- | --- | --- | --- | --- | --- | --- | --- | --- | --- | --- | --- | --- | --- | --- | --- | --- | --- | --- | --- | --- | --- | --- | --- | --- | --- | --- | --- | --- | --- | --- | --- | --- | --- | --- | --- | --- | --- | --- | --- | --- | --- | --- | --- | --- | --- | --- | --- |
|  | 3 | **1.3 CONSTRUCTION ACCELERATOR SYSTEMS** |  | 2009-01-02 | 2014-10-30 |  |  |  |  |  |  |  |  |  |  |  |  |  |  |  |  |  |  |  |  |  |  |  |  |  |  |  |  |  |  |  |  |  |  |  |  |  |  |  |  |  |  |  |  |  |  |
|  | 1 | **1.3.1 CRYOMODULES** |  | 2009-01-26 | 2013-08-30 |  |  |  |  |  |  |  |  |  |  |  |  |  |  |  |  |  |  |  |  |  |  |  |  |  |  |  |  |  |  |  |  |  |  |  |  |  |  |  |  |  |  |  |  |  |  |
|  | 1 | **1.3.1.1 PROCUREMENTS** |  | 2009-01-26 | 2013-08-30 |  |  |  |  |  |  |  |  |  |  |  |  |  |  |  |  |  |  |  |  |  |  |  |  |  |  |  |  |  |  |  |  |  |  |  |  |  |  |  |  |  |  |  |  |  |  |
|  | 1 | **1.3.1.1.1 CAVITY STRING PROCUREMENTS** |  | 2009-01-26 | 2013-08-30 |  |  |  |  |  |  |  |  |  |  |  |  |  |  |  |  |  |  |  |  |  |  |  |  |  |  |  |  |  |  |  |  |  |  |  |  |  |  |  |  |  |  |  |  |  |  |
|  | 1 | **1.3.1.1.1.1 NIOBIUM** |  | 2009-01-26 | 2013-08-30 |  |  |  |  |  |  |  |  |  |  |  |  |  |  |  |  |  |  |  |  |  |  |  |  |  |  |  |  |  |  |  |  |  |  |  |  |  |  |  |  |  |  |  |  |  |  |
| 131111010 |  | Proc Niobium | 112d | 2009-01-26 A | 2009-07-03 A | 9-090M FS+60d | 100% | 2009-01-26 | 2009-07-02 | MECH ENG [8 h]; SCIENTIST [8 h]; MECH DES [40 h] | 2,778.16 | 2,778.16 | 0 | 2778.16 | HOGAN J | 1 | 1 | H | JOHN H | 08-050 | 10-027 | 10-064 | 11-051 | 12-018F |  |  |  |  |  |  |  |  |  |  |  |  |  |  |  |  |  |  |  |  |  |  |  |  |  |  |  |
| 131111011 |  | Niobium Labor and Expenses Initial | 80d | 2009-05-01 A | 2009-08-24 A | 131111010 | 100% |  |  | ELEC ENG [60 h]; MECH ENG [100 h]; SR STAFF [100 h]; SCIENTIST [24 h]; SUPPLIES & MATERIALS; MECH DES [100 h]; TRAVEL | 28,932.43 | 26,445.04 | 0 | 28932.43 | HOGAN J | 1 | 1 | S | JOHN H | 08-050 | 10-027 | 10-064 | 11-051 | 12-018F | APP | 3111B | ST | 09-032 | 09-032 |  |  |  |  |  |  |  |  |  |  |  |  |  |  |  |  |  |  |  |  |  |  |
| 131111012 |  | Expenses Niobium Batch 1 | 105d | 2009-07-01 A | 2009-11-30 A | 131111010 | 100% |  |  | SUPPLIES & MATERIALS; TRAVEL | 2,294.62 |  | 0 | 2294.62 | HOGAN J | 1 | 1 | H | JOHN H | 08-050 | 10-027 | 10-064 | 11-051 | 12-018F | APP | 3111B |  | 09-032 | 09-032 | 09-012 |  |  |  |  |  |  |  |  |  |  |  |  |  |  |  |  |  |  |  |  |  |
| 131111012A |  | Vend Fab - Order Niobium | 38d | 2009-07-01 A | 2009-08-24 A | 9-090M FS+193d | 100% |  |  | PROCUREMENT<$50K 60; PROCUREMENT>$50K 69 | 355,042.38 |  | 0 | 355042.38 | HOGAN J | 1 | 1 | P | JOHN H | 08-050 | 10-027 | 10-064 | 11-051 | 12-018F | APP | 3111B |  | 09-032 | 09-032 |  | 0 | 355042.38 | 35504238 | 100 | 09-037 |  |  |  |  |  |  |  |  |  |  |  |  |  |  |  |  |
| 131111012B |  | Vend Fab - Niobium Batch 1 | 105d | 2009-07-01 A | 2009-11-30 A | 9-090M FS+193d | 100% |  |  | PROCUREMENT>$50K 69 NO ESCALATION | 634,004.25 |  | 0 | 634004.25 | HOGAN J | 1 | 1 | P | JOHN H | 08-050 | 10-027 | 10-064 | 11-051 | 12-018F | APP | 3111B |  | 09-032 | 09-032 |  | 0 | 634004.25 | 63400425 | 100 | 09-037 | 10-001A |  |  |  |  |  |  |  |  |  |  |  |  |  |  |  |
| 131111013 |  | Expenses Niobium Batch 2 | 268d | 2009-07-01 A | 2010-07-29 A | 131111010 | 100% |  |  | SUPPLIES & MATERIALS; TRAVEL | 2,294.62 |  | 0 | 2294.62 | HOGAN J | 1 | 1 | H | JOHN H | 08-050 | 10-027 | 10-064 | 11-051 | 12-018F | APP | 3111B |  | 09-032 | 09-032 | 09-012 |  |  |  |  |  |  | 07-027 | 08-016 |  |  |  |  |  |  |  |  |  |  |  |  |  |
| 131111013A |  | Vend Fab - Niobium Batch 2 | 162d | 2009-07-01 A | 2010-03-01 A | 9-090M FS+193d | 100% |  |  | PROCUREMENT>$50K 69 NO ESCALATION | 1,546,970.37 |  | 0 | 1546970.37 | HOGAN J | 1 | 1 | P | JOHN H | 08-050 | 10-027 | 10-064 | 11-051 | 12-018F | APP | 3111B |  | 09-032 | 09-032 |  | 0 | 1546970.37 | 154697037 | 100 | 09-037 | 10-001A | 07-027 | 08-016 |  |  |  |  |  |  |  |  |  |  |  |  |  |
| 131111011LOE |  | Niobium Labor and Expenses Final FY09 | 56d | 2009-07-14 A | 2009-09-30 A | 131111011 FS-200d | 100% |  |  | SUPPLIES & MATERIALS; MECH DES [8.52 h]; TRAVEL; ELEC ENG [5.68 h]; MECH ENG [8.52 h]; SR STAFF [7.81 h]; SCIENTIST [3.55 h] | 2,827.53 | 2,313.31 | 0 | 2827.5278 | HOGAN J | 1 | 1 | E | JOHN H | 08-050 | 10-027 | 10-064 | 11-051 | 12-018F | APP | 3111B |  | 09-032 | 09-032 |  |  |  |  |  |  | 10-001B |  |  | 100 | 100 |  |  |  |  |  |  |  |  |  |  |  |
| 131111011LOEb |  | Niobium Labor and Expenses Final FY10 | 100d | 2009-10-01 A | 2010-03-03 A | 131111011LOE | 100% |  |  | MECH DES [15.48 h]; TRAVEL; ELEC ENG [10.32 h]; MECH ENG [15.48 h]; SR STAFF [14.19 h]; SCIENTIST [6.45 h]; SUPPLIES & MATERIALS | 5,301.92 | 4,337.13 | 0 | 5301.907124 | HOGAN J | 1 | 1 | E | JOHN H |  | 10-027 | 10-064 | 11-051 | 12-018F | APP | 3111B |  |  |  |  |  |  |  |  |  | 10-001B |  |  | 100 | 100 |  |  |  |  |  |  |  |  |  |  |  |
| 131111015 |  | Receive & Insp Niobium Batch 1 | 33d | 2009-11-02 A | 2009-12-21 A | 131111012B | 100% | 2009-11-02 | 2009-12-18 | MECH DES [80 h]; MECH ENG [80 h]; SCIENTIST [40 h]; SR STAFF [200 h]; SUPPLIES & MATERIALS; MECH TECH [240 h]; ELEC ENG [80 h]; COMP SCIENT [120 h] | 60,015.19 | 55,477.2 | 0 | 60015.18663 | HOGAN J | 1 | 1 | H | JOHN H | 08-050 | 10-027 | 10-064 | 11-051 | 12-018F |  |  |  | 09-032 | 09-032 |  |  |  |  |  |  |  |  |  |  |  |  |  |  |  |  |  |  |  |  |  |  |
| 131111013B |  | Vend Fab - Niobium Batch 2 Reverse Entry per CR 10-043 | 1d | 2010-03-01 A | 2010-03-01 A | 9-100M FS+97d | 100% |  |  | PROCUREMENT>$50K 69 NO ESCALATION | -1,546,970.37 |  |  |  | HOGAN J | 1 | 1 | N/A | JOHN H |  |  | 10-064 | 11-051 | 12-018F | APP | 3111B |  |  |  |  |  |  |  | 100 |  |  |  |  |  |  | 10-043 |  |  |  |  |  |  |  |  |  |  |
| 131111013C |  | Vend Fab - Niobium Batch 2 Revised Delivery per CR 10-043 | 108d | 2010-03-01 A | 2010-07-30 A | 9-100M FS+97d | 100% |  |  | PROCUREMENT>$50K 69 NO ESCALATION | 1,546,970.37 |  | 0 | 1546970.37 | HOGAN J | 1 | 1 | D | JOHN H |  |  | 10-064 | 11-051 | 12-018F | APP | 3111B |  |  |  |  | 0 | 1546970.37 | 154697037 | 100 |  |  |  |  |  |  | 10-043 |  |  |  |  |  |  |  |  |  |  |
| 131111020 |  | Receive & Insp Niobium Batch 2 (Original History) | 1d | 2010-03-01 A | 2010-03-01 A | 131111013A | 100% |  |  | MECH DES [20 h]; MECH TECH [240 h]; MECH ENG [40 h]; ELEC ENG [80 h]; SUPPLIES & MATERIALS | 20,258.95 | 18,858 | 0 | 20258.95 | HOGAN J | 1 | 1 | H | JOHN H | 08-050 | 10-027 | 10-064 | 11-051 | 12-018F |  |  |  | 09-032 | 09-032 |  |  |  |  |  |  |  |  |  |  |  | 10-043 |  |  |  |  |  |  |  |  |  |  |
| 131111020A |  | Receive & Insp Niobium Batch 2 Reverse Entry per CR 10-043 | 1d | 2010-03-01 A | 2010-03-01 A | 131111013B, 9-100M FS+97d | 100% |  |  | MECH DES [-20 h]; MECH TECH [-240 h]; MECH ENG [-40 h]; SUPPLIES & MATERIALS; ELEC ENG [-80 h] | -20,258.95 | -18,858 |  |  | HOGAN J | 1 | 1 | N/A | JOHN H |  |  | 10-064 | 11-051 | 12-018F |  |  |  |  |  |  |  |  |  |  |  |  |  |  |  |  | 10-043 |  |  |  |  |  |  |  |  |  |  |
| 131111020B |  | Receive & Insp Niobium Batch 2 Revised Delivery per CR 10-043 | 43d | 2010-06-01 A | 2010-07-30 A | 131111013C FS-10d | 100% |  |  | MECH TECH [480 h]; MECH ENG [80 h]; SUPPLIES & MATERIALS; ELEC ENG [160 h]; MECH DES [40 h] | 40,517.9 | 37,716 | 0 | 40517.9 | HOGAN J | 1 | 1 | H | JOHN H |  |  | 10-064 | 11-051 | 12-018F |  |  |  |  |  |  |  |  |  |  |  |  |  |  |  |  | 10-043 |  |  |  |  |  |  |  |  |  |  |
| 131111025 |  | Re-Baseline Actuals Adjustment | 1d | 2013-08-30 A | 2013-08-30 A |  | 100% | 2010-06-01 | 2010-06-01 | PROCUREMENT>$50K 69 NO ESCALATION | 62,672.03 |  | 0 | 62672.03 | HOGAN J | 1 | 1 | H | JOHN H |  |  | 10-064 | 11-051 | 12-018F |  |  |  |  |  |  | 0 | 62672.03 | 6267203 | 100 |  |  |  |  |  |  | 10-043 | ADJ |  |  |  |  |  |  |  |  |  |
|  | 2 | **1.3.1.1.1.2 CAVITY FABRICATION** |  | 2009-01-26 | 2013-08-30 |  |  |  |  |  |  |  |  |  |  |  |  |  |  |  |  |  |  |  |  |  |  |  |  |  |  |  |  |  |  |  |  |  |  |  |  |  |  |  |  |  |  |  |  |  |  |
| 131112000 |  | Re-Baseline Actuals Adjustment | 1d | 2013-08-30 A | 2013-08-30 A |  | 100% | 2013-09-03 | 2013-09-03 | PROCUREMENT>$50K 69 NO ESCALATION | 21,000.2 |  |  | 21000.2 |  |  |  |  |  |  |  |  |  |  |  |  |  |  |  |  | 0 | 21000.2 | 2100020 | 100 |  |  |  |  |  |  |  | ADJ |  |  |  |  |  |  |  |  |  |
|  | 1 | **1.3.1.1.1.2.1 VEND FAB CAVITIES** |  | 2009-01-26 | 2011-09-22 |  |  |  |  |  |  |  |  |  |  |  |  |  |  |  |  |  |  |  |  |  |  |  |  |  |  |  |  |  |  |  |  |  |  |  |  |  |  |  |  |  |  |  |  |  |  |
| 1311121010 |  | Proc Cavity Fab | 112d | 2009-01-26 A | 2009-07-03 A | 121113005, 9-090M FS+60d | 100% | 2009-01-26 | 2009-07-02 | MECH DES [40 h]; MECH ENG [40 h] | 4,306 | 4,306 | 0 | 4306 | HOGAN J | 1 | 1 | H | JOHN H | 08-050 | 10-027 | 10-064 | 11-051 | 12-018F |  |  |  |  |  |  |  |  |  |  |  |  |  |  |  |  |  |  |  |  |  |  |  |  |  |  |  |
| 1311121015 |  | Cavities Labor Initial | 42d | 2009-05-01 A | 2009-06-30 A | 1311121010 | 100% |  |  | MECH ENG [70 h]; SCIENTIST [50 h]; SR STAFF [50 h]; MECH DES [70.4 h]; ELEC ENG [61.6 h] | 19,864.61 | 19,864.61 | 0 | 19864.604 | HOGAN J | 1 | 1 | H | JOHN H | 08-050 | 10-027 | 10-064 | 11-051 | 12-018F | APP | 3111C |  | 09-032 | 09-032 | 09-012 |  |  |  |  |  |  |  | 08-016 |  |  |  |  |  |  |  |  |  |  |  |  |  |
| 1311121015LOE |  | Cavities Labor Final FY09 | 56d | 2009-07-14 A | 2009-09-30 A | 1311121015 | 100% |  |  | SR STAFF [7.46 h]; MECH DES [9.53 h]; ELEC ENG [2.02 h]; MECH ENG [9.69 h]; SCIENTIST [3.26 h] | 2,142.54 | 2,142.54 | 0 | 2142.5327 | HOGAN J | 1 | 1 | E | JOHN H | 08-050 | 10-027 | 10-064 | 11-051 | 12-018F | APP | 3111C |  | 09-032 | 09-032 |  |  |  |  |  |  | 10-001B |  | 08-016 | 100 | 100 |  |  |  |  |  |  |  |  |  |  |  |
| 1311121016 |  | Vend Fab Cavities 1 & 2 | 218d | 2009-09-14 A | 2010-07-30 A | 9-090M FS+193d | 100% |  |  | PROCUREMENT>$50K 69 NO ESCALATION | 83,288 |  | 0 | 83288 | HOGAN J | 1 | 1 | D | JOHN H | 08-050 | 10-027 | 10-064 | 11-051 |  | APP | 3111C |  | 09-032 | 09-032 |  | 0 | 83288 | 8328800 | 100 | 09-037 |  |  | 08-016 |  |  | 10-043 |  | 09-039 | 10-023 | 11-003 | 11-012 |  |  |  |  |  |
| 1311121020 |  | Vend Fab Cavities 3 thru 8 | 260d | 2009-09-14 A | 2010-09-29 A | 1311121016 FS-191d | 100% |  |  | PROCUREMENT>$50K 69 NO ESCALATION | 249,864 |  | 0 | 249864 | HOGAN J | 1 | 1 | D | JOHN H | 08-050 | 10-027 | 10-064 | 11-051 |  |  |  | NB | 09-032 | 09-032 |  | 0 | 249864 | 24986400 | 100 | 09-037 |  |  |  |  |  |  |  | 09-039 | 10-023 | 11-003 | 11-012 | 09-017 |  |  |  |  |
| 1311121025 |  | Vend Fab Cavities 9 thru 14 | 273d | 2009-09-14 A | 2010-10-18 A | 1311121020 FS-214d | 100% |  |  | PROCUREMENT>$50K 69 NO ESCALATION | 249,864 |  | 0 | 249864 | HOGAN J | 1 | 1 | D | JOHN H | 08-050 | 10-027 | 10-064 | 11-051 |  |  |  |  | 09-032 | 09-032 |  | 0 | 249864 | 24986400 | 100 | 09-037 |  |  |  |  |  |  |  | 09-039 | 10-023 | 11-003 | 11-012 | 09-017 |  |  |  |  |
| 1311121030 |  | Vend Fab Cavities 15 thru 20 | 278d | 2009-09-14 A | 2010-10-25 A | 1311121025 FS-233d | 100% |  |  | PROCUREMENT>$50K 69 NO ESCALATION | 249,864 |  | 0 | 249864 | HOGAN J | 1 | 1 | D | JOHN H | 08-050 | 10-027 | 10-064 | 11-051 |  |  |  |  | 09-032 | 09-032 |  | 0 | 249864 | 24986400 | 100 | 09-037 |  |  |  |  |  |  |  | 09-039 | 10-023 | 11-003 | 11-012 | 09-017 |  |  |  |  |
| 1311121035 |  | Vend Fab Cavities 21 thru 26 | 278d | 2009-09-14 A | 2010-10-25 A | 1311121030 FS-287.88d | 100% |  |  | PROCUREMENT>$50K 69 NO ESCALATION | 249,864 |  | 0 | 249864 | HOGAN J | 1 | 1 | D | JOHN H | 08-050 | 10-027 | 10-064 | 11-051 | 12-018F |  |  |  | 09-032 | 09-032 |  | 0 | 249864 | 24986400 | 100 |  |  |  |  |  |  |  |  | 09-039 | 10-023 |  | 11-012 | 09-017 |  |  |  |  |
| 1311121040 |  | Vend Fab Cavities 27 thru 32 | 278d | 2009-09-14 A | 2010-10-25 A | 1311121035 FS-274d | 100% |  |  | PROCUREMENT>$50K 69 NO ESCALATION | 249,864 |  | 0 | 249864 | HOGAN J | 1 | 1 | D | JOHN H | 08-050 | 10-027 | 10-064 | 11-051 | 12-018F |  |  |  | 09-032 | 09-032 |  | 0 | 249864 | 24986400 | 100 |  |  |  |  |  |  |  |  | 09-039 | 10-023 | 11-003 | 11-012 | 09-017 |  |  |  |  |
| 1311121045 |  | Vend Fab Cavities 33 thru 38 | 302d | 2009-09-14 A | 2010-11-30 A | 1311121040 FS-293d | 100% |  |  | PROCUREMENT>$50K 69 NO ESCALATION | 249,864 |  | 0 | 249864 | HOGAN J | 1 | 1 | D | JOHN H | 08-050 | 10-027 | 10-064 | 11-051 | 12-018F |  |  |  | 09-032 | 09-032 |  | 0 | 249864 | 24986400 | 100 |  |  |  |  |  |  |  |  | 09-039 | 10-023 | 11-003 | 11-012 | 09-017 |  |  |  |  |
| 1311121050 |  | Vend Fab Cavities 39 thru 44 | 302d | 2009-09-14 A | 2010-11-30 A | 1311121045 FS-335d | 100% |  |  | PROCUREMENT>$50K 69 NO ESCALATION | 249,864 |  | 0 | 249864 | HOGAN J | 1 | 1 | D | JOHN H | 08-050 | 10-027 | 10-064 | 11-051 | 12-018F |  |  |  | 09-032 | 09-032 |  | 0 | 249864 | 24986400 | 100 |  |  |  |  |  |  |  |  | 09-039 | 10-023 | 11-003 | 11-012 | 09-017 |  |  |  |  |
| 1311121055 |  | Vend Fab Cavities 45 thru 50 | 302d | 2009-09-14 A | 2010-11-30 A | 1311121050 FS-350d | 100% |  |  | PROCUREMENT>$50K 69 NO ESCALATION | 249,864 |  | 0 | 249864 | HOGAN J | 1 | 1 | D | JOHN H | 08-050 | 10-027 |  | 11-051 | 12-018F |  |  |  | 09-032 | 09-032 |  | 0 | 249864 | 24986400 | 100 |  |  |  |  |  |  |  |  | 09-039 | 10-023 | 11-003 | 11-012 | 09-017 |  |  |  |  |
| 1311121060 |  | Vend Fab Cavities 51 thru 56 | 302d | 2009-09-14 A | 2010-11-30 A | 1311121055 FS-370d | 100% |  |  | PROCUREMENT>$50K 69 NO ESCALATION | 249,864 |  | 0 | 249864 | HOGAN J | 1 | 1 | D | JOHN H | 08-050 | 10-027 | 10-064 | 11-051 | 12-018F |  |  |  | 09-032 | 09-032 |  | 0 | 249864 | 24986400 | 100 |  |  |  |  |  |  |  |  | 09-039 | 10-023 | 11-003 | 11-012 | 09-017 |  |  |  |  |
| 1311121065 |  | Vend Fab Cavities 57 thru 62 | 302d | 2009-09-14 A | 2010-11-30 A | 1311121060 FS-387d | 100% |  |  | PROCUREMENT>$50K 69 NO ESCALATION | 249,864 |  | 0 | 249864 | HOGAN J | 1 | 1 | D | JOHN H | 08-050 | 10-027 | 10-064 | 11-051 | 12-018F | APP | 3111C |  | 09-032 | 09-032 |  | 0 | 249864 | 24986400 | 100 |  |  | 07-027 |  |  |  |  |  | 09-039 | 10-023 | 11-003 | 11-012 | 09-017 | 07-024 |  |  |  |
| 1311121070 |  | Vend Fab Cavities 63 thru 68 | 302d | 2009-09-14 A | 2010-11-30 A | 1311121065 FS-407d | 100% |  |  | PROCUREMENT>$50K 69 NO ESCALATION | 249,864 |  | 0 | 249864 | HOGAN J | 1 | 1 | D | JOHN H | 08-050 | 10-027 | 10-064 | 11-051 | 12-018F |  |  |  | 09-032 | 09-032 |  | 0 | 249864 | 24986400 | 100 |  |  |  |  |  |  |  |  | 09-039 | 10-023 | 11-003 | 11-012 | 09-017 |  |  |  |  |
| 1311121075 |  | Vend Fab Cavities 69 thru 74 | 315d | 2009-09-14 A | 2010-12-17 A | 1311121070 FS-427d | 100% |  |  | PROCUREMENT>$50K 69 NO ESCALATION | 249,864 |  | 0 | 249864 | HOGAN J | 1 | 1 | D | JOHN H | 08-050 | 10-027 | 10-064 | 11-051 | 12-018F |  |  |  | 09-032 | 09-032 |  | 0 | 249864 | 24986400 | 100 |  |  |  |  |  |  |  |  | 09-039 | 10-023 | 11-003 |  | 09-017 |  |  |  |  |
| 1311121080 |  | Vend Fab Cavities 75 thru 80 | 316d | 2009-09-14 A | 2010-12-21 A | 1311121075 FS-448d | 100% | 2009-09-14 | 2010-12-20 | PROCUREMENT>$50K 69 NO ESCALATION | 249,864 |  | 0 | 249864 | HOGAN J | 1 | 1 | D | JOHN H | 08-050 | 10-027 | 10-064 | 11-051 | 12-018F |  |  |  | 09-032 | 09-032 |  | 0 | 249864 | 24986400 | 100 |  |  | 07-027 |  |  |  |  |  | 09-039 | 10-023 | 11-003 |  | 09-017 | 07-024 |  |  |  |
| 1311121085 |  | Vend Fab Cavities 81 thru 86 | 377d | 2009-09-14 A | 2011-03-25 A | 1311121080 FS-467d | 100% |  |  | PROCUREMENT>$50K 69 NO ESCALATION | 249,864 |  | 0 | 249864 | HOGAN J | 1 | 1 | D | JOHN H | 08-050 | 10-027 | 10-064 | 11-051 | 12-018F |  |  |  | 09-032 | 09-032 |  | 0 | 249864 | 24986400 | 100 |  |  | 07-027 |  |  |  |  |  | 09-039 | 10-023 | 11-003 |  | 09-017 | 07-024 |  |  |  |
| 1311121015LOEb |  | Cavities Labor Final FY10 | 457d | 2009-10-01 A | 2011-08-08 A | 1311121015LOE | 100% | 2009-10-01 | 2011-08-05 | MECH ENG [43.7 h]; SCIENTIST [14.7 h]; SR STAFF [33.65 h]; MECH DES [42.98 h]; ELEC ENG [9.09 h] | 10,115.61 | 10,126.34 | 0 | 9970.149196 | HOGAN J | 1 | 1 | E | JOHN H |  | 10-027 | 10-064 | 11-051 | 12-018F | APP | 3111C |  |  |  |  |  |  |  |  |  | 10-001B |  |  | 100 | 100 |  |  |  |  |  |  |  |  | 1.31004366 | 98.68995633 | 11-001 |
| 1311121015LOEc |  | Cavities Labor Final FY11 | 457d | 2009-10-01 A | 2011-08-08 A | 1311121015LOE | 100% | 2009-10-01 | 2011-08-05 | MECH ENG [37.01 h]; SCIENTIST [12.44 h]; SR STAFF [28.49 h]; MECH DES [36.39 h]; ELEC ENG [7.69 h] | 8,564.43 | 8,573.54 | 0 | 8710.564503 | HOGAN J | 1 | 1 | E | JOHN H |  | 10-027 | 10-064 | 11-051 | 12-018F | APP | 3111C |  |  |  |  |  |  |  |  |  | 10-001B |  |  | 100 | 100 |  |  |  |  |  |  |  |  | 1.31004366 | 98.68995633 | 11-001 |
| 1311121017 |  | Vend Fab Chemistry & Tuning Cavities 1 & 2 | 146d | 2010-01-04 A | 2010-07-30 A | 9-100M FS+22d | 100% |  |  | PROCUREMENT<$50K 60 NO ESCALATION | 17,441.56 |  | 0 | 17441.56 | HOGAN J | 1 | 1 | D | JOHN H |  | 10-027 | 10-064 | 11-051 |  | APP | 3111C | NB |  |  |  | 0 | 17441.56 | 1744156 | 100 |  |  |  |  |  |  | 10-043 |  | 09-039 | 10-023 | 11-003 | 11-012 |  |  |  |  |  |
| 1311121021 |  | Vend Fab Chemistry & Tuning Cavities 3 thru 8 | 188d | 2010-01-04 A | 2010-09-29 A | 9-100M FS+22d | 100% |  |  | PROCUREMENT>$50K 69 NO ESCALATION; PROCUREMENT<$50K 60 NO ESCALATION | 52,324.67 |  | 0 | 52324.67 | HOGAN J | 1 | 1 | D | JOHN H |  | 10-027 | 10-064 | 11-051 |  | APP | 3111C |  |  |  |  | 0 | 52324.67 | 5232467 | 100 |  |  |  |  |  |  |  |  | 09-039 | 10-023 | 11-003 | 11-012 |  |  |  |  |  |
| 1311121026 |  | Vend Fab Chemistry & Tuning Cavities 9 thru 14 | 206d | 2010-01-04 A | 2010-10-25 A | 9-100M FS+22d | 100% |  |  | PROCUREMENT>$50K 69 NO ESCALATION | 52,324.67 |  | 0 | 52324.67 | HOGAN J | 1 | 1 | D | JOHN H |  | 10-027 | 10-064 | 11-051 |  | APP | 3111C |  |  |  |  | 0 | 52324.67 | 5232467 | 100 |  |  |  |  |  |  |  |  | 09-039 | 10-023 | 11-003 | 11-012 |  |  |  |  |  |
| 1311121031 |  | Vend Fab Chemistry & Tuning Cavities 15 thru 20 | 206d | 2010-01-04 A | 2010-10-25 A | 9-100M FS+22d | 100% |  |  | PROCUREMENT>$50K 69 NO ESCALATION | 52,324.67 |  | 0 | 52324.67 | HOGAN J | 1 | 1 | D | JOHN H |  | 10-027 | 10-064 | 11-051 |  | APP | 3111C |  |  |  |  | 0 | 52324.67 | 5232467 | 100 |  |  |  |  |  |  |  |  | 09-039 | 10-023 | 11-003 | 11-012 |  |  |  |  |  |
| 1311121036 |  | Vend Fab Chemistry & Tuning Cavities 21 thru 26 | 206d | 2010-01-04 A | 2010-10-25 A | 9-100M FS+22d | 100% |  |  | PROCUREMENT>$50K 69 NO ESCALATION | 52,324.67 |  | 0 | 52324.67 | HOGAN J | 1 | 1 | D | JOHN H |  | 10-027 | 10-064 | 11-051 | 12-018F | APP | 3111C |  |  |  |  | 0 | 52324.67 | 5232467 | 100 |  |  |  |  |  |  |  |  | 09-039 | 10-023 |  | 11-012 |  |  |  |  |  |
| 1311121041 |  | Vend Fab Chemistry & Tuning Cavities 27 thru 32 | 206d | 2010-01-04 A | 2010-10-25 A | 9-100M FS+22d | 100% |  |  | PROCUREMENT>$50K 69 NO ESCALATION | 52,324.67 |  | 0 | 52324.67 | HOGAN J | 1 | 1 | D | JOHN H |  | 10-027 | 10-064 | 11-051 | 12-018F | APP | 3111C |  |  |  |  | 0 | 52324.67 | 5232467 | 100 |  |  |  |  |  |  |  |  | 09-039 | 10-023 | 11-003 | 11-012 |  |  |  |  |  |
| 1311121046 |  | Vend Fab Chemistry & Tuning Cavities 33 thru 38 | 230d | 2010-01-04 A | 2010-11-30 A | 9-100M FS+22d | 100% |  |  | PROCUREMENT>$50K 69 NO ESCALATION | 52,324.67 |  | 0 | 52324.67 | HOGAN J | 1 | 1 | D | JOHN H |  | 10-027 | 10-064 | 11-051 | 12-018F | APP | 3111C |  |  |  |  | 0 | 52324.67 | 5232467 | 100 |  |  |  |  |  |  |  |  | 09-039 | 10-023 | 11-003 | 11-012 |  |  |  |  |  |
| 1311121051 |  | Vend Fab Chemistry & Tuning Cavities 39 thru 44 | 230d | 2010-01-04 A | 2010-11-30 A | 9-100M FS+22d | 100% |  |  | PROCUREMENT>$50K 69 NO ESCALATION | 52,324.67 |  | 0 | 52324.67 | HOGAN J | 1 | 1 | D | JOHN H |  | 10-027 | 10-064 | 11-051 | 12-018F | APP | 3111C |  |  |  |  | 0 | 52324.67 | 5232467 | 100 |  |  |  |  |  |  |  |  | 09-039 | 10-023 | 11-003 | 11-012 |  |  |  |  |  |
| 1311121056 |  | Vend Fab Chemistry & Tuning Cavities 45 thru 50 | 230d | 2010-01-04 A | 2010-11-30 A | 9-100M FS+22d | 100% |  |  | PROCUREMENT>$50K 69 NO ESCALATION | 52,324.67 |  | 0 | 52324.67 | HOGAN J | 1 | 1 | D | JOHN H |  | 10-027 |  | 11-051 | 12-018F | APP | 3111C |  |  |  |  | 0 | 52324.67 | 5232467 | 100 |  |  |  |  |  |  |  |  | 09-039 | 10-023 | 11-003 | 11-012 |  |  |  |  |  |
| 1311121061 |  | Vend Fab Chemistry & Tuning Cavities 51 thru 56 | 230d | 2010-01-04 A | 2010-11-30 A | 9-100M FS+22d | 100% |  |  | PROCUREMENT>$50K 69 NO ESCALATION | 52,324.67 |  | 0 | 52324.67 | HOGAN J | 1 | 1 | D | JOHN H |  | 10-027 | 10-064 | 11-051 | 12-018F | APP | 3111C |  |  |  |  | 0 | 52324.67 | 5232467 | 100 |  |  |  |  |  |  |  |  | 09-039 | 10-023 | 11-003 | 11-012 |  |  |  |  |  |
| 1311121066 |  | Vend Fab Chemistry & Tuning Cavities 57 thru 62 | 230d | 2010-01-04 A | 2010-11-30 A | 9-100M FS+22d | 100% |  |  | PROCUREMENT>$50K 69 NO ESCALATION | 52,324.67 |  | 0 | 52324.67 | HOGAN J | 1 | 1 | D | JOHN H |  | 10-027 | 10-064 | 11-051 | 12-018F | APP | 3111C |  |  |  |  | 0 | 52324.67 | 5232467 | 100 |  |  |  |  |  |  |  |  | 09-039 | 10-023 | 11-003 | 11-012 |  |  |  |  |  |
| 1311121071 |  | Vend Fab Chemistry & Tuning Cavities 63 thru 68 | 230d | 2010-01-04 A | 2010-11-30 A | 9-100M FS+22d | 100% |  |  | PROCUREMENT>$50K 69 NO ESCALATION | 52,324.67 |  | 0 | 52324.67 | HOGAN J | 1 | 1 | D | JOHN H |  | 10-027 | 10-064 | 11-051 | 12-018F | APP | 3111C |  |  |  |  | 0 | 52324.67 | 5232467 | 100 |  |  |  |  |  |  |  |  | 09-039 | 10-023 | 11-003 | 11-012 |  |  |  |  |  |
| 1311121076 |  | Vend Fab Chemistry & Tuning Cavities 69 thru 74 | 243d | 2010-01-04 A | 2010-12-17 A | 9-100M FS+22d | 100% |  |  | PROCUREMENT>$50K 69 NO ESCALATION | 52,324.67 |  | 0 | 52324.67 | HOGAN J | 1 | 1 | D | JOHN H |  | 10-027 | 10-064 | 11-051 | 12-018F | APP | 3111C |  |  |  |  | 0 | 52324.67 | 5232467 | 100 |  |  |  |  |  |  |  |  | 09-039 | 10-023 | 11-003 |  |  |  |  |  |  |
| 1311121081 |  | Vend Fab Chemistry & Tuning Cavities 75 thru 80 | 245d | 2010-01-04 A | 2010-12-21 A | 9-100M FS+22d | 100% |  |  | PROCUREMENT>$50K 69 NO ESCALATION | 52,324.67 |  | 0 | 52324.67 | HOGAN J | 1 | 1 | D | JOHN H |  | 10-027 | 10-064 | 11-051 | 12-018F | APP | 3111C |  |  |  |  | 0 | 52324.67 | 5232467 | 100 |  |  |  |  |  |  |  |  | 09-039 | 10-023 | 11-003 |  |  |  |  |  |  |
| 1311121086 |  | Vend Fab Chemistry & Tuning Cavities 81 thru 86 | 305d | 2010-01-04 A | 2011-03-25 A | 9-100M FS+22d | 100% |  |  | PROCUREMENT>$50K 69 NO ESCALATION | 52,324.67 |  | 0 | 52324.67 | HOGAN J | 1 | 1 | D | JOHN H |  | 10-027 | 10-064 | 11-051 | 12-018F | APP | 3111C |  |  |  |  | 0 | 52324.67 | 5232467 | 100 |  |  |  |  |  |  |  |  | 09-039 | 10-023 | 11-003 |  |  |  |  |  |  |
| 1311121091 |  | Cavities Custom Duty Adjustment | 180d | 2010-07-01 A | 2011-03-25 A | 9-100M FS+184d | 100% |  |  | PROCUREMENT>$50K 69 NO ESCALATION | 50,000 |  | 0 | 50000 | HOGAN J | 1 | 1 | D | JOHN H |  |  | 10-064 | 11-051 | 12-018F | APP | 3111C |  |  |  |  | 0 | 50000 | 5000000 | 100 |  |  |  |  |  |  |  |  |  |  | 11-003 |  |  |  |  |  |  |
| 1311121096LOE |  | SOTR Oversight FY10 | 64d | 2010-07-01 A | 2010-09-30 A | 9-100M FS+184d | 100% |  |  | SCIENTIST [104 h] | 6,896.24 | 6,896.24 | 0 | 6896.24 | HOGAN J | 1 | 1 | E | JOHN H |  |  | 10-064 | 11-051 | 12-018F |  |  |  |  |  |  |  |  |  |  |  |  |  |  | 100 | 100 |  |  |  |  |  |  |  |  |  |  |  |
| 1311121101LOE |  | SOTR Oversight FY11 | 242d | 2010-10-01 A | 2011-09-22 A | 1311121096LOE | 100% |  |  | SCIENTIST [400 h] | 27,372 | 27,372 | 0 | 27372 | HOGAN J | 1 | 1 | E | JOHN H |  |  | 10-064 | 11-051 | 12-018F |  |  |  |  |  |  |  |  |  |  |  |  |  |  | 100 | 100 |  |  |  |  |  |  |  |  | 6.1983471 | 93.80165289 |  |

Notes:
- 131111011: Steps: Contract Prep (done); Venor Selected (done); Vendor Places PO for Niobium (done)
- 1311121020: Explanation: During the scheduling of this activity for Change Request / 10-023 the finish date was input as 28 May 2010 and should have benn input / as 25 June 2010 - PMI error. (PMC)
- 1311121035: Steps: Receive and Inspect #1 thru #8; Recieve and Inspect #9 thru #16; Recieve and Inspect #17 thru #20
- 1311121017: Explanation: During the scheduling of this activity for Change Request / 10-023 the finish date was input as 28 May 2010 and should have benn input / as 25 June 2010 - PMI error. (PMC)

| ID | WBS | Activity | Type | Duration | Start | Finish | Predecessors | Complete | Planned start | Planned finish | Resources | Cost | Actual cost | Calculated Remaining Total Cost | MONTHLY EV COST | RESP - Responsibility | STRT%COMP for CM EVM | FNSH%COMP for CM EVM | Advance Purchase Plan > 500K | EVMS Reporting Codes | CAM RESPONSIBLE | CR 08-050 | 12 GEV MAJOR PROCUREMENT CATAGORY | Activities with Steps | CR 09-017 | CR 09-032 | CR 09-032 Repair | CR 10-023 | CR 10-027 | CR 10-043 | CR 10-064 | CR 11-003 | CR 11-012 | CR 11-051 | CR 12-018 | CR 12-001 | CR 07-024 | CR 07-027 |
| --- | --- | --- | --- | --- | --- | --- | --- | --- | --- | --- | --- | --- | --- | --- | --- | --- | --- | --- | --- | --- | --- | --- | --- | --- | --- | --- | --- | --- | --- | --- | --- | --- | --- | --- | --- | --- | --- | --- |
|  | 2 | **1.3.1.1.1.2.2 RECEIVE AND INSPECT CAVITIES** |  |  | 2010-07-19 | 2011-08-22 |  |  |  |  |  |  |  |  |  |  |  |  |  |  |  |  |  |  |  |  |  |  |  |  |  |  |  |  |  |  |  |  |
| 1311122005 |  | Receive and Inspect Cavities 1 & 2 |  | 26d | 2010-07-19 A | 2010-08-23 A | 1311121017 FS-14d, 1311121016 FS-14d | 100% |  |  | MECH ENG [46.7 h]; MECH TECH [60.13 h]; SCIENTIST [20 h]; SR STAFF [15 h]; SUPPLIES & MATERIALS; COMP SCIENT [30 h]; ELEC ENG [40 h]; ELEC TECH [30 h]; MECH DES [30 h] | 16,118.56 | 15,603.13 | 0 | 16118.55525 | HOGAN J | 1 | 1 | APP | S | JOHN H | 08-050 | 3111C | ST | 09-017 | 09-032 | 09-032 | 10-023 | 10-027 | 10-043 | 10-064 | 11-003 | 11-012 | 11-051 |  |  |  |  |
| 1311122010 |  | Receive and Inspect Cavities 3 Thru 8 |  | 15d | 2010-09-01 A | 2010-09-22 A | 1311121021 FS-45d, 1311122005 FS-10d, 1311121020 FS-45d | 100% |  |  | MECH DES [60 h]; ELEC ENG [120 h]; MECH ENG [120 h]; SCIENTIST [48 h]; SR STAFF [30 h]; ELEC TECH [60 h]; MECH TECH [240 h]; SUPPLIES & MATERIALS; COMP SCIENT [60 h] | 42,683.37 | 41,137.08 | 0 | 42683.371831 | HOGAN J | 1 | 1 |  | S | JOHN H | 08-050 |  | ST | 09-017 | 09-032 | 09-032 |  | 10-027 |  | 10-064 | 11-003 | 11-012 | 11-051 |  |  |  |  |
| 1311122015 |  | Receive and Inspect Cavities 9 Thru 14 |  | 12d | 2010-10-01 A | 2010-10-18 A | 1311122010, 1311121025 FS-15d, 1317000, 1311121026 FS-15d | 100% |  |  | COMP SCIENT [30 h]; ELEC ENG [120 h]; MECH ENG [90 h]; SR STAFF [30 h]; SUPPLIES & MATERIALS; ELEC TECH [30 h]; MECH TECH [240 h]; MECH DES [30 h]; SCIENTIST [48 h] | 37,365.33 | 35,819.04 | 0 | 36258.571831 | HOGAN J | 1 | 1 |  | S | JOHN H | 08-050 |  | ST | 09-017 | 09-032 | 09-032 | 10-023 | 10-027 |  | 10-064 | 11-003 | 11-012 | 11-051 |  |  |  |  |
| 1311122020 |  | Receive and Inspect Cavities 15 and 16 |  | 20d | 2010-11-01 A | 2010-11-30 A | 1311122015, 1311121031 FS-15d, 1311121030 FS-15d, 1317000 | 100% |  |  | MECH DES [10 h]; MECH ENG [30 h]; SCIENTIST [16 h]; SR STAFF [10 h]; SUPPLIES & MATERIALS; ELEC TECH [10 h]; MECH TECH [80 h]; COMP SCIENT [10 h]; ELEC ENG [40 h] | 12,471.55 | 11,939.68 | 0 | 12471.55 | HOGAN J | 1 | 1 |  | S | JOHN H | 08-050 |  | ST | 09-017 | 09-032 | 09-032 | 10-023 | 10-027 |  | 10-064 | 11-003 | 11-012 | 11-051 |  |  |  |  |
| 1311122022 |  | Receive and Inspect Cavities 17 Thru 20 |  | 20d | 2010-11-01 A | 2010-11-30 A | 1317000, 1311122020 | 100% |  |  | SUPPLIES & MATERIALS; ELEC TECH [40 h]; MECH TECH [160 h]; ELEC ENG [80 h]; MECH DES [20 h]; MECH ENG [60 h]; SCIENTIST [32 h]; SR STAFF [20 h] | 24,526.7 | 23,462.96 | 0 | 24526.7 | HOGAN J | 1 | 1 |  | S | JOHN H | 08-050 |  | ST | 09-017 | 09-032 | 09-032 | 10-023 | 10-027 |  | 10-064 |  | 11-012 | 11-051 | 12-018F |  |  |  |
| 1311122025 |  | Receive and Inspect Cavities 21 Thru 24 |  | 20d | 2010-11-01 A | 2010-11-30 A | 1311122022, 1311121036 FS-16d, 1311121035 FS-16d | 100% |  |  | MECH DES [20 h]; SCIENTIST [32 h]; ELEC ENG [80 h]; MECH ENG [60 h]; SUPPLIES & MATERIALS; ELEC TECH [40 h]; MECH TECH [160 h] | 22,336.5 | 21,272.76 | 0 | 22336.5 | HOGAN J | 1 | 1 |  | S | JOHN H | 08-050 |  | ST | 09-017 | 09-032 | 09-032 | 10-023 | 10-027 |  | 10-064 |  | 11-012 | 11-051 | 12-018F |  |  |  |
| 1311122027 |  | Receive and Inspect Cavities 25 and 26 |  | 20d | 2010-11-01 A | 2010-11-30 A | 1311122025 | 100% |  |  | MECH ENG [13 h]; SCIENTIST [16 h]; SUPPLIES & MATERIALS; ELEC TECH [10 h]; MECH TECH [80 h]; SR STAFF [10 h]; ELEC ENG [40 h]; MECH DES [10 h] | 10,680.5 | 10,148.63 | 0 | 10680.5 | HOGAN J | 1 | 1 |  | S | JOHN H | 08-050 |  | ST | 09-017 | 09-032 | 09-032 | 10-023 | 10-027 |  | 10-064 | 11-003 | 11-012 | 11-051 | 12-018F |  |  |  |
| 1311122030 |  | Receive and Inspect Cavities 27 Thru 32 |  | 20d | 2010-11-01 A | 2010-11-30 A | 1311121040 FS-17d, 1311121041 FS-17d, 1311122027 | 100% |  |  | ELEC TECH [30 h]; MECH DES [30 h]; MECH ENG [39 h]; MECH TECH [240 h]; SCIENTIST [48 h]; SR STAFF [30 h]; SUPPLIES & MATERIALS; ELEC ENG [120 h] | 32,041.51 | 30,445.89 | 0 | 32041.51 | HOGAN J | 1 | 1 |  | S | JOHN H | 08-050 |  | ST | 09-017 | 09-032 | 09-032 | 10-023 | 10-027 |  | 10-064 | 11-003 | 11-012 | 11-051 | 12-018F |  |  |  |
| 1311122035 |  | Receive and Inspect Cavities 33 Thru 38 |  | 13d | 2010-12-01 A | 2010-12-17 A | 1317005, 1311122030, 1311121045 FS-12d, 1311121046 FS-12d | 100% |  |  | MECH DES [15 h]; ELEC ENG [120 h]; SR STAFF [30 h]; MECH ENG [39 h]; SCIENTIST [48 h]; SUPPLIES & MATERIALS; ELEC TECH [30 h]; MECH TECH [240 h] | 31,341.31 | 29,745.69 | 0 | 31341.31 | HOGAN J | 1 | 1 |  | S | JOHN H | 08-050 |  | ST | 09-017 | 09-032 | 09-032 | 10-023 | 10-027 |  | 10-064 | 11-003 | 11-012 | 11-051 | 12-018F |  |  |  |
| 1311122065 |  | Receive and Inspect Cavities 39 and 40 |  | 13d | 2010-12-01 A | 2010-12-17 A | 1311122035, 1311121050 FS-16d, 1311121051 FS-16d | 100% |  |  | ELEC ENG [40 h]; SUPPLIES & MATERIALS; SR STAFF [10 h]; MECH ENG [13 h]; SCIENTIST [16 h]; MECH TECH [80 h]; MECH DES [5 h]; ELEC TECH [10 h] | 10,447.1 | 9,915.23 | 0 | 10447.1 | HOGAN J | 1 | 1 |  | S | JOHN H | 08-050 |  | ST | 09-017 | 09-032 | 09-032 | 10-023 | 10-027 |  | 10-064 | 11-003 | 11-012 | 11-051 | 12-018F |  |  |  |
| 1311122067 |  | Receive and Inspect Cavities 41 Thru 44 |  | 13d | 2010-12-01 A | 2010-12-17 A | 1311122065 | 100% |  |  | SUPPLIES & MATERIALS; ELEC TECH [20 h]; MECH TECH [160 h]; MECH DES [10 h]; SR STAFF [20 h]; MECH ENG [26 h]; SCIENTIST [32 h]; ELEC ENG [80 h] | 20,894.2 | 19,830.46 | 0 | 20894.2 | HOGAN J | 1 | 1 |  | S | JOHN H | 08-050 |  | ST | 09-017 | 09-032 | 09-032 | 10-023 | 10-027 |  | 10-064 | 11-003 | 11-012 | 11-051 | 12-018F |  |  |  |
| 1311122070 |  | Receive and Inspect Cavities 45 Thru 48 |  | 9d | 2011-01-03 A | 2011-01-14 A | 1311121056 FS+4d, 1311122067, 1311121055 FS+4d | 100% | 2011-01-04 | 2011-01-14 | ELEC TECH [20 h]; MECH DES [10 h]; ELEC ENG [80 h]; MECH TECH [160 h]; SR STAFF [20 h]; MECH ENG [26 h]; SCIENTIST [32 h]; SUPPLIES & MATERIALS | 20,894.2 | 19,830.46 | 0 | 20894.2 | HOGAN J | 1 | 1 |  | S | JOHN H | 08-050 |  | ST | 09-017 | 09-032 | 09-032 |  | 10-027 |  | 10-064 | 11-003 | 11-012 | 11-051 | 12-018F |  |  |  |
| 1311122072 |  | Receive and Inspect Cavities 49 and 50 |  | 5d | 2011-01-14 A | 2011-01-21 A | 1311122070 | 100% |  |  | MECH ENG [13 h]; SCIENTIST [16 h]; SUPPLIES & MATERIALS; ELEC TECH [10 h]; ELEC ENG [40 h]; MECH TECH [80 h]; MECH DES [5 h]; SR STAFF [10 h] | 10,447.1 | 9,915.23 | 0 | 10447.1 | HOGAN J | 1 | 1 |  | S | JOHN H | 08-050 |  | ST | 09-017 | 09-032 | 09-032 |  | 10-027 |  | 10-064 | 11-003 | 11-012 | 11-051 | 12-018F |  |  |  |
| 1311122075 |  | Receive and Inspect Cavities 51 Thru 56 |  | 6d | 2011-01-24 A | 2011-01-31 A | 1311121061 FS-2d, 1311121060 FS-2d, 1311122072 | 100% |  |  | SUPPLIES & MATERIALS; ELEC TECH [30 h]; ELEC ENG [120 h]; MECH TECH [240 h]; MECH DES [15 h]; SR STAFF [30 h]; MECH ENG [39 h]; SCIENTIST [48 h] | 31,341.31 | 29,745.69 | 0 | 31341.31 | HOGAN J | 1 | 1 |  | S | JOHN H | 08-050 |  | ST | 09-017 | 09-032 | 09-032 |  | 10-027 |  | 10-064 | 11-003 | 11-012 | 11-051 | 12-018F |  |  |  |
| 1311122080 |  | Receive and Inspect Cavities 57 Thru 62 |  | 15d | 2011-03-01 A | 2011-03-21 A | 1311122075, 1311121066 FS-3d, 1311121065 FS-3d | 100% |  |  | MECH TECH [240 h]; MECH DES [15 h]; MECH ENG [39 h]; SCIENTIST [48 h]; SUPPLIES & MATERIALS; ELEC ENG [120 h]; ELEC TECH [30 h] | 28,056.01 | 26,460.39 | 0 | 28056.01 | HOGAN J | 1 | 1 |  | S | JOHN H | 08-050 |  | ST | 09-017 | 09-032 | 09-032 |  | 10-027 |  | 10-064 | 11-003 | 11-012 | 11-051 | 12-018F |  |  |  |
| 1311122085 |  | Receive and Inspect Cavities 63 and 64 |  | 12d | 2011-04-01 A | 2011-04-18 A | 1311122080, 1311121070 FS-4d, 1311121071 FS-4d | 100% |  |  | MECH ENG [13 h]; SCIENTIST [16 h]; SUPPLIES & MATERIALS; ELEC TECH [10 h]; MECH TECH [80 h]; MECH DES [5 h]; ELEC ENG [40 h] | 9,352 | 8,820.13 | 0 | 9352 | HOGAN J | 1 | 1 |  | S | JOHN H | 08-050 |  | ST | 09-017 | 09-032 | 09-032 |  | 10-027 |  | 10-064 | 11-003 | 11-012 | 11-051 | 12-018F |  |  |  |
| 1311122087 |  | Receive and Inspect Cavities 65 thru 68 |  | 11d | 2011-05-02 A | 2011-05-16 A | 1311122085 | 100% |  |  | ELEC TECH [20 h]; MECH TECH [160 h]; ELEC ENG [80 h]; SCIENTIST [32 h]; SUPPLIES & MATERIALS; MECH ENG [26 h] | 18,237.2 | 17,173.46 | 0 | 18237.2 | HOGAN J | 1 | 1 |  | S | JOHN H | 08-050 |  | ST | 09-017 | 09-032 | 09-032 |  | 10-027 |  | 10-064 | 11-003 | 11-012 | 11-051 | 12-018F |  |  |  |
| 1311122090 |  | Receive and Inspect Cavities 69 Thru 72 |  | 11d | 2011-06-01 A | 2011-06-15 A | 1311122087, 1311121075 FS-5d, 1311121076 FS-5d | 100% |  |  | MECH TECH [160 h]; SCIENTIST [32 h]; ELEC ENG [80 h]; SUPPLIES & MATERIALS; MECH ENG [26 h]; ELEC TECH [20 h] | 18,237.2 | 17,173.46 | 0 | 18237.2 | HOGAN J | 1 | 1 |  | S | JOHN H | 08-050 |  | ST | 09-017 | 09-032 | 09-032 |  | 10-027 |  | 10-064 | 11-003 | 11-012 | 11-051 | 12-018F |  |  |  |
| 1311122092 |  | Receive and Inspect Cavities 73 and 74 |  | 3d | 2011-06-18 A | 2011-06-22 A | 1311122090 | 100% | 2011-06-20 | 2011-06-22 | SUPPLIES & MATERIALS; MECH ENG [13 h]; ELEC TECH [10 h]; MECH TECH [80 h]; ELEC ENG [40 h]; SCIENTIST [16 h] | 9,118.6 | 8,586.73 | 0 | 9118.6 | HOGAN J | 1 | 1 |  | S | JOHN H | 08-050 |  | ST | 09-017 | 09-032 | 09-032 |  | 10-027 |  | 10-064 | 11-003 | 11-012 | 11-051 | 12-018F |  |  |  |
| 1311122095 |  | Receive and Inspect Cavities 75 Thru 80 |  | 12d | 2011-07-01 A | 2011-07-19 A | 1311122092, 1311121080 FS-6d, 1311121081 FS-6d | 100% |  |  | SUPPLIES & MATERIALS; MECH ENG [39 h]; ELEC TECH [30 h]; MECH TECH [240 h]; ELEC ENG [120 h]; SCIENTIST [48 h] | 27,355.81 | 25,760.19 | 0 | 27355.81 | HOGAN J | 1 | 1 |  | S | JOHN H | 08-050 |  | ST | 09-017 | 09-032 | 09-032 |  | 10-027 |  | 10-064 | 11-003 | 11-012 | 11-051 | 12-018F |  |  |  |
| 1311122100 |  | Receive and Inspect Cavities 81 Thru 86 FY11 |  | 31d | 2011-07-11 A | 2011-08-22 A | 1311121085 FS-6d, 1311121091, 1311122095, 1311121086 FS-6d | 100% |  |  | SUPPLIES & MATERIALS; MECH ENG [48.53 h]; ELEC TECH [37.33 h]; MECH TECH [224 h]; SCIENTIST [44.8 h]; ELEC ENG [112 h] | 27,251.78 | 25,266.11 | 0 | 27251.7916 | HOGAN J | 1 | 1 |  | S | JOHN H | 08-050 |  | ST | 09-017 | 09-032 | 09-032 |  | 10-027 |  | 10-064 | 11-003 | 11-012 | 11-051 | 12-018F | 12-001 |  |  |
| 1311122100a |  | Receive and Inspect Cavities 81 Thru 86 FY12 |  | 31d | 2011-07-11 A | 2011-08-22 A | 1311122100 | 100% |  |  | ELEC ENG [8 h]; MECH ENG [3.47 h]; ELEC TECH [2.67 h]; MECH TECH [16 h]; SUPPLIES & MATERIALS; SCIENTIST [3.2 h] | 1,951.48 | 1,805.13 | 0 | 2008.9655 | HOGAN J | 1 | 1 |  | S | JOHN H | 08-050 |  | ST | 09-017 | 09-032 | 09-032 |  | 10-027 |  | 10-064 | 11-003 | 11-012 | 11-051 | 12-018F | 12-001 |  |  |
| 1311122105M |  | All Cavities Recieved and Inspected | milestone | 0d | 2011-08-22 A | 2011-08-22 A | 1311122100, 1311122027, 1311122072, 1311122025, 1311122085, 1311122095, 1311122087, 131111013, 131111015, 131111020A, 1311122092, 1311122070, 1311122022, 1311122030, 131111011LOEb FF, 1311122015, 1311122090, 1311122100a, 1311121101LOE FS-30d, 131111020B, 1311122035 FF, 1311122065, 1311121015LOEb, 1311121015LOEc, 131111012 FF, 131111013A, 131111020, 1311122020, 1311122075 FF, 131111012A, 1311122010, 1311122005, 1311122080, 1311122067 | 100% | 2011-10-25 | 2011-10-25 |  |  |  |  | 0 | HOGAN J | 1 | 1 |  | M | JOHN H | 08-050 |  |  | 09-017 | 09-032 | 09-032 |  | 10-027 |  | 10-064 | 11-003 | 11-012 | 11-051 | 12-018F |  | 07-024 | 07-027 |

Notes:
- 1311122005: Steps: Receive and Inspect Cavity 1 (done); Receive and Inspect Cavity 2 (done)
- 1311122010: Steps: Receive and Inspect Cavity 3 (done); Receive and Inspect Cavity 4 (done); Receive and Inspect Cavity 5 (done); Receive and Inspect Cavity 6 (done); Receive and Inspect Cavity 7 (done); Receive and Inspect Cavity 8 (done)
- 1311122015: Steps: Receive and Inspect Cavity 9 (done); Receive and Inspect Cavity 10 (done); Receive and Inspect Cavity 11 (done); Receive and Inspect Cavity 12 (done); Receive and Inspect Cavity 13 (done); Receive and Inspect Cavity 14 (done)
- 1311122020: Steps: Receive and Inspect Cavity 15 (done); Receive and Inspect Cavity 16 (done)
- 1311122022: Steps: Receive and Inspect Cavity 17 (done); Receive and Inspect Cavity 18 (done); Receive and Inspect Cavity 19 (done); Receive and Inspect Cavity 20 (done)
- 1311122025: Steps: Receive and Inspect Cavity 21 (done); Receive and Inspect Cavity 22 (done); Receive and Inspect Cavity 23 (done); Receive and Inspect Cavity 24 (done)
- 1311122027: Steps: Receive and Inspect Cavity 25 (done); Receive and Inspect Cavity 26 (done)
- 1311122030: Steps: Receive and Inspect Cavity 27 (done); Receive and Inspect Cavity 28 (done); Receive and Inspect Cavity 29 (done); Receive and Inspect Cavity 30 (done); Receive and Inspect Cavity 31 (done); Receive and Inspect Cavity 32 (done)
- 1311122035: Steps: Receive and Inspect Cavity 33 (done); Receive and Inspect Cavity 34 (done); Receive and Inspect Cavity 35 (done); Receive and Inspect Cavity 36 (done); Receive and Inspect Cavity 37 (done); Receive and Inspect Cavity 38 (done)
- 1311122065: Steps: Receive and Inspect Cavity 39 (done); Receive and Inspect Cavity 40 (done)
- 1311122067: Steps: Receive and Inspect Cavity 41 (done); Receive and Inspect Cavity 42 (done); Receive and Inspect Cavity 43 (done); Receive and Inspect Cavity 44 (done)
- 1311122070: Steps: Receive and Inspect Cavity 45 (done); Receive and Inspect Cavity 46 (done); Receive and Inspect Cavity 47 (done); Receive and Inspect Cavity 48 (done)
- 1311122072: Steps: Receive and Inspect Cavity 49 (done); Receive and Inspect Cavity 50 (done)
- 1311122075: Steps: Receive and Inspect Cavity 51 (done); Receive and Inspect Cavity 52 (done); Receive and Inspect Cavity 53 (done); Receive and Inspect Cavity 54 (done); Receive and Inspect Cavity 55 (done); Receive and Inspect Cavity 56 (done)
- 1311122080: Steps: Receive and Inspect Cavity 57 (done); Receive and Inspect Cavity 58 (done); Receive and Inspect Cavity 59 (done); Receive and Inspect Cavity 60 (done); Receive and Inspect Cavity 61 (done); Receive and Inspect Cavity 62 (done)
- 1311122085: Steps: Receive and Inspect Cavity 63 (done); Receive and Inspect Cavity 64 (done)
- 1311122087: Steps: Receive and Inspect Cavity 65 (done); Receive and Inspect Cavity 66 (done); Receive and Inspect Cavity 67 (done); Receive and Inspect Cavity 68 (done)
- 1311122090: Steps: Receive and Inspect Cavity 69 (done); Receive and Inspect Cavity 70 (done); Receive and Inspect Cavity 71 (done); Receive and Inspect Cavity 72 (done)
- 1311122092: Steps: Receive and Inspect Cavity 73 (done); Receive and Inspect Cavity 74 (done)
- 1311122095: Steps: Receive and Inspect Cavity 75 (done); Receive and Inspect Cavity 76 (done); Receive and Inspect Cavity 77 (done); Receive and Inspect Cavity 78 (done); Receive and Inspect Cavity 79 (done); Receive and Inspect Cavity 80 (done)
- 1311122100: Steps: Receive and Inspect Cavity 81 (done); Receive and Inspect Cavity 82 (done); Receive and Inspect Cavity 83 (done); Receive and Inspect Cavity 84 (done); Receive and Inspect Cavity 85 (done); Receive and Inspect Cavity 86 (done)
- 1311122100a: Steps: Receive and Inspect Cavities 21 thru 24 (done); Receive and Inspect Cavities 25 thru 32 (done); Receive and Inspect Cavities 33 thru 40 (done); Receive and Inspect Cavities 41 thru 48 (done); Receive and Inspect Cavities 49 thru 56 (done)

| ID | WBS | Activity | Type | Duration | Start | Finish | Predecessors | Complete | Planned start | Planned finish | Resources | Cost | Actual cost | Remaining Material Cost Based on % Compl | Claimed Material Cost Based on % Complet | Initial Claimed Material Calc | Claimed Material Divider | MONTHLY EV COST | ReBaseline Actuals Adjustment | Calculated Remaining Total Cost | RESP - Responsibility | STRT%COMP for CM EVM | FNSH%COMP for CM EVM | EVMS Reporting Codes | CAM RESPONSIBLE | CR 08-050 | CR 10-027 | CR 10-064 | CR 11-051 | CR 12-018 | CR 07-027 | Advance Purchase Plan > 500K | CR 08-016 | 12 GEV MAJOR PROCUREMENT CATAGORY | CR 09-012 | CR 09-032 | CR 09-032 Repair | CR 10-001 | CR 11-003 | CR 11-012 | CR 12-028 | LOE Divider | LOE Multiplier | Activities with Steps | CR 09-017 | CR 07-024 |
| --- | --- | --- | --- | --- | --- | --- | --- | --- | --- | --- | --- | --- | --- | --- | --- | --- | --- | --- | --- | --- | --- | --- | --- | --- | --- | --- | --- | --- | --- | --- | --- | --- | --- | --- | --- | --- | --- | --- | --- | --- | --- | --- | --- | --- | --- | --- |
|  | 3 | **1.3.1.1.1.2.3 DUMMY** |  |  |  |  |  |  |  |  |  |  |  |  |  |  |  |  |  |  |  |  |  |  |  |  |  |  |  |  |  |  |  |  |  |  |  |  |  |  |  |  |  |  |  |  |
|  | 3 | **1.3.1.1.1.3 WAVEGUIDES** |  |  | 2009-01-26 | 2013-08-30 |  |  |  |  |  |  |  |  |  |  |  |  |  |  |  |  |  |  |  |  |  |  |  |  |  |  |  |  |  |  |  |  |  |  |  |  |  |  |  |  |
| 131113000 |  | Re-Baseline Actuals Adjustment |  | 1d | 2013-08-30 A | 2013-08-30 A |  | 100% | 2013-09-03 | 2013-09-03 | PROCUREMENT>$50K 69 NO ESCALATION | 179,043.2 |  | 0 | 179043.2 | 17904320 | 100 | 179043.2 | ADJ |  |  |  |  |  |  |  |  |  |  |  |  |  |  |  |  |  |  |  |  |  |  |  |  |  |  |  |
|  | 1 | **1.3.1.1.1.3.1 WAVEGUIDES FABRICATION** |  |  | 2009-01-26 | 2011-09-11 |  |  |  |  |  |  |  |  |  |  |  |  |  |  |  |  |  |  |  |  |  |  |  |  |  |  |  |  |  |  |  |  |  |  |  |  |  |  |  |  |
| 1311131010 |  | Proc Waveguides |  | 68d | 2009-01-26 A | 2009-04-30 A | 11115005 FS-250d, 9-090M FS+60d | 100% |  |  | MECH DES [80 h]; MECH ENG [40 h] | 6,059.6 | 6,059.6 |  |  |  |  | 6059.6 |  | 0 | HOGAN J | 1 | 1 | H | JOHN H | 08-050 | 10-027 | 10-064 | 11-051 | 12-018F |  |  |  |  |  |  |  |  |  |  |  |  |  |  |  |  |
| 1311131015 |  | Waveguides Labor Initial |  | 95d | 2009-05-01 A | 2009-09-15 A | 1311131010 | 100% |  |  | MECH ENG [100 h]; SR STAFF [40 h]; SUPPLIES & MATERIALS; TRAVEL; ELEC ENG [60 h]; MECH DES [80 h] | 35,711.2 | 17,855.6 |  |  |  |  | 35711.2 |  | 0 | HOGAN J | 1 | 1 | H | JOHN H | 08-050 | 10-027 | 10-064 | 11-051 | 12-018F | 07-027 | APP | 08-016 | 3111A | 09-012 | 09-032 | 09-032 |  |  |  |  |  |  |  |  |  |
| 1311131020 |  | Vend Fab Waveguides 1 thru 10 |  | 175d | 2009-05-01 A | 2010-01-18 A | 9-090M FS+162d | 100% | 2009-05-01 | 2010-01-15 | PROCUREMENT>$50K 69 NO ESCALATION; PROCUREMENT<$50K 60 NO ESCALATION | 55,500 |  | 0 | 55500 | 5550000 | 100 | 55500 |  | 0 | HOGAN J | 1 | 1 | P | JOHN H | 08-050 | 10-027 | 10-064 | 11-051 |  |  |  |  |  |  | 09-032 | 09-032 | 10-001A | 11-003 |  |  |  |  |  |  |  |
| 1311131025 |  | Vend Fab Waveguides 11 thru 30 |  | 264d | 2009-05-01 A | 2010-05-24 A | 1311131020 FS-73d | 100% |  |  | PROCUREMENT<$50K 60 NO ESCALATION; PROCUREMENT>$50K 69 NO ESCALATION | 111,000 |  | 0 | 111000 | 11100000 | 100 | 111000 |  | 0 | HOGAN J | 1 | 1 | D | JOHN H | 08-050 | 10-027 | 10-064 | 11-051 |  |  |  |  |  |  | 09-032 | 09-032 | 10-001A | 11-003 | 11-012 |  |  |  |  |  |  |
| 1311131030 |  | Vend Fab Waveguides 31 thru 40 |  | 311d | 2009-05-01 A | 2010-07-30 A | 1311131025 FS-114d | 100% |  |  | PROCUREMENT<$50K 60 NO ESCALATION; PROCUREMENT>$50K 69 NO ESCALATION | 42,270 |  | 0 | 42270 | 4227000 | 100 | 42270 |  | 0 | HOGAN J | 1 | 1 | D | JOHN H | 08-050 | 10-027 | 10-064 | 11-051 | 12-018F |  |  |  |  |  | 09-032 | 09-032 | 10-001A | 11-003 |  | 12-028F |  |  |  |  |  |
| 1311131035 |  | Vend Fab Waveguides 41 thru 50 |  | 327d | 2009-05-01 A | 2010-08-23 A | 1311131030 FS-164d | 100% |  |  | PROCUREMENT<$50K 60 NO ESCALATION; PROCUREMENT>$50K 69 NO ESCALATION | 42,270 |  | 0 | 42270 | 4227000 | 100 | 42270 |  | 0 | HOGAN J | 1 | 1 | D | JOHN H | 08-050 | 10-027 | 10-064 | 11-051 | 12-018F |  |  |  |  |  | 09-032 | 09-032 | 10-001A |  |  |  |  |  |  |  |  |
| 1311131040 |  | Vend Fab Waveguides 51 thru 60 |  | 395d | 2009-05-01 A | 2010-11-30 A | 1311131035 FS-184d | 100% |  |  | PROCUREMENT<$50K 60 NO ESCALATION; PROCUREMENT>$50K 69 NO ESCALATION | 42,270 |  | 0 | 42270 | 4227000 | 100 | 42270 |  | 0 | HOGAN J | 1 | 1 | D | JOHN H | 08-050 | 10-027 | 10-064 | 11-051 | 12-018F |  |  |  |  |  | 09-032 | 09-032 | 10-001A |  |  |  |  |  |  |  |  |
| 1311131045 |  | Vend Fab Waveguides 61 thru 70 |  | 451d | 2009-05-01 A | 2011-02-28 A | 1311131040 FS-206d | 100% |  |  | PROCUREMENT<$50K 60 NO ESCALATION; PROCUREMENT>$50K 69 NO ESCALATION | 42,270 |  | 0 | 42270 | 4227000 | 100 | 42270 |  | 0 | HOGAN J | 1 | 1 | D | JOHN H | 08-050 | 10-027 | 10-064 | 11-051 | 12-018F |  |  |  |  |  | 09-032 | 09-032 | 10-001A |  |  |  |  |  |  |  |  |
| 1311131050 |  | Vend Fab Waveguides 71 thru 80 |  | 491d | 2009-05-01 A | 2011-04-25 A | 1311131045 FS-227d | 100% |  |  | PROCUREMENT>$50K 69 NO ESCALATION; PROCUREMENT<$50K 60 NO ESCALATION | 42,270 |  | 0 | 42270 | 4227000 | 100 | 42270 |  | 0 | HOGAN J | 1 | 1 | D | JOHN H | 08-050 | 10-027 | 10-064 | 11-051 | 12-018F |  |  |  |  |  | 09-032 | 09-032 | 10-001A |  |  |  |  |  |  |  |  |
| 1311131055 |  | Vend Fab Waveguides 81 thru 88 |  | 530d | 2009-05-01 A | 2011-06-20 A | 1311131050 FS-249d | 100% |  |  | PROCUREMENT<$50K 60 NO ESCALATION; PROCUREMENT>$50K 69 NO ESCALATION | 33,816 |  | 0 | 33816 | 3381600 | 100 | 33816 |  | 0 | HOGAN J | 1 | 1 | D | JOHN H | 08-050 | 10-027 | 10-064 | 11-051 | 12-018F |  |  |  |  |  | 09-032 | 09-032 | 10-001A |  |  |  |  |  |  |  |  |
| 1311131015LOE |  | Waveguides Labor Final FY09 |  | 64d | 2009-07-01 A | 2009-09-30 A | 1311131015 FS-200d | 100% |  |  | ELEC ENG [15.45 h]; MECH DES [20.6 h]; MECH ENG [25.75 h]; SR STAFF [10.3 h]; TRAVEL | 6,169.19 | 4,597.81 |  |  |  |  | 6169.197 |  | 0 | HOGAN J | 1 | 1 | E | JOHN H | 08-050 | 10-027 | 10-064 | 11-051 | 12-018F | 07-027 | APP | 08-016 | 3111A |  | 09-032 | 09-032 | 10-001B |  |  |  | 100 | 100 |  |  |  |
| 1311131015LOEb |  | Waveguides Labor Final FY10 |  | 248d | 2009-10-01 A | 2010-09-30 A | 1311131015LOE | 100% |  |  | TRAVEL; ELEC ENG [44.55 h]; MECH DES [59.4 h]; MECH ENG [74.25 h]; SR STAFF [29.7 h] | 18,356.67 | 13,680.71 |  |  |  |  | 18356.672979 |  | 0 | HOGAN J | 1 | 1 | E | JOHN H |  | 10-027 | 10-064 | 11-051 | 12-018F |  | APP |  | 3111A |  |  |  | 10-001B |  |  |  | 100 | 100 |  |  |  |
| 1311131060 |  | Exchange Rate |  | 297d | 2010-07-01 A | 2011-09-11 A | 1311131010 | 100% | 2010-07-01 | 2011-09-09 | PROCUREMENT<$50K 60 NO ESCALATION | 50,000 |  | 0 | 50000 | 5000000 | 100 | 50000 |  | 0 | HOGAN J | 1 | 1 | D | JOHN H |  |  | 10-064 | 11-051 | 12-018F |  |  |  |  |  |  |  |  |  |  |  |  |  |  |  |  |
|  | 2 | **1.3.1.1.1.3.2 WAVEGUIDES RECEIVE AND INSPECT** |  |  | 2010-01-18 | 2011-09-30 |  |  |  |  |  |  |  |  |  |  |  |  |  |  |  |  |  |  |  |  |  |  |  |  |  |  |  |  |  |  |  |  |  |  |  |  |  |  |  |  |
| 1311132010 |  | Receive & Insp Waveguides 1 thru 8 |  | 23d | 2010-01-18 A | 2010-02-19 A | 1311131020 | 100% | 2010-01-19 | 2010-02-19 | MECH DES [96 h]; MECH ENG [64 h]; COMP SCIENT [32 h]; ELEC ENG [96 h]; SR STAFF [64 h]; SUPPLIES & MATERIALS; ELEC TECH [32 h]; MECH TECH [128 h] | 30,601.98 | 30,352 |  |  |  |  | 30601.977775 |  | 0 | HOGAN J | 1 | 1 | S | JOHN H | 08-050 | 10-027 | 10-064 | 11-051 |  |  |  |  |  |  | 09-032 | 09-032 |  | 11-003 |  |  |  |  | ST |  |  |
| 1311132015 |  | Receive & Insp Waveguides 9 & 10 |  | 19d | 2010-02-01 A | 2010-02-26 A | 1311132010 | 100% |  |  | COMP SCIENT [8 h]; ELEC ENG [24 h]; SUPPLIES & MATERIALS; MECH DES [24 h]; MECH ENG [16 h]; ELEC TECH [8 h]; MECH TECH [32 h]; SR STAFF [16 h] | 7,651.18 | 7,588 |  |  |  |  | 7651.183237 |  | 0 | HOGAN J | 1 | 1 | S | JOHN H | 08-050 | 10-027 | 10-064 | 11-051 |  |  |  |  |  |  | 09-032 | 09-032 |  | 11-003 | 11-012 |  |  |  | ST |  |  |
| 1311132020 |  | Receive & Insp Waveguides 11 thru 16 |  | 45d | 2010-02-18 A | 2010-04-21 A | 1311131025 FS-15d, 1311132015 | 100% |  |  | ELEC TECH [24 h]; MECH DES [24 h]; MECH ENG [48 h]; MECH TECH [96 h]; ELEC ENG [48 h]; COMP SCIENT [24 h]; SR STAFF [48 h]; SUPPLIES & MATERIALS | 19,189.34 | 19,002 |  |  |  |  | 19189.341445 |  | 0 | HOGAN J | 1 | 1 | S | JOHN H | 08-050 | 10-027 | 10-064 | 11-051 |  |  |  |  |  |  | 09-032 | 09-032 |  | 11-003 | 11-012 |  |  |  | ST |  |  |
| 1311132025 |  | Receive & Insp Waveguides 17 Thru 20 |  | 17d | 2010-04-05 A | 2010-04-27 A | 1311132020 | 100% |  |  | MECH TECH [64 h]; COMP SCIENT [16 h]; ELEC ENG [32 h]; SR STAFF [32 h]; SUPPLIES & MATERIALS; MECH DES [16 h]; MECH ENG [32 h]; ELEC TECH [16 h] | 12,792.98 | 12,668 |  |  |  |  | 12792.983728 |  | 0 | HOGAN J | 1 | 1 | S | JOHN H | 08-050 | 10-027 | 10-064 | 11-051 | 12-018F |  |  |  |  |  | 09-032 | 09-032 |  | 11-003 | 11-012 | 12-028F |  |  | ST |  |  |
| 1311132030 |  | Receive & Insp Waveguides 21 thru 24 |  | 40d | 2010-04-26 A | 2010-06-21 A | 1311132025 | 100% |  |  | MECH DES [16 h]; ELEC TECH [16 h]; MECH TECH [64 h]; MECH ENG [32 h]; COMP SCIENT [14.4 h]; ELEC ENG [32 h]; SUPPLIES & MATERIALS | 9,298.55 | 9,173.57 |  |  |  |  | 9298.551728 |  | 0 | HOGAN J | 1 | 1 | S | JOHN H | 08-050 | 10-027 | 10-064 | 11-051 | 12-018F |  |  |  |  |  | 09-032 | 09-032 |  | 11-003 | 11-012 | 12-028F |  |  | ST |  |  |
| 1311132035 |  | Receive & Insp Waveguides 25 thru 30 |  | 33d | 2010-06-15 A | 2010-07-30 A | 1311132030 | 100% |  |  | MECH DES [24 h]; MECH ENG [48 h]; ELEC TECH [24 h]; MECH TECH [96 h]; COMP SCIENT [21.6 h]; ELEC ENG [48 h]; SUPPLIES & MATERIALS | 13,947.69 | 13,760.35 |  |  |  |  | 13947.693445 |  | 0 | HOGAN J | 1 | 1 | S | JOHN H | 08-050 | 10-027 | 10-064 | 11-051 | 12-018F |  |  |  |  |  | 09-032 | 09-032 |  | 11-003 |  | 12-028F |  |  | ST | 09-017 |  |
| 1311132040 |  | Receive & Insp Waveguides 31 and 32 |  | 6d | 2010-08-02 A | 2010-08-09 A | 1311132035, 1311131030 | 100% |  |  | MECH TECH [32 h]; SUPPLIES & MATERIALS; MECH DES [3.2 h]; MECH ENG [16 h]; ELEC TECH [8 h] | 2,928.83 | 2,865.65 |  |  |  |  | 2928.831237 |  | 0 | HOGAN J | 1 | 1 | S | JOHN H | 08-050 | 10-027 | 10-064 | 11-051 | 12-018F |  |  |  |  |  | 09-032 | 09-032 |  | 11-003 |  | 12-028F |  |  | ST | 09-017 |  |
| 1311132045 |  | Receive & Insp Waveguides 33 thru 40 |  | 6d | 2010-08-09 A | 2010-08-16 A | 1311132040 | 100% |  |  | MECH DES [12.8 h]; MECH ENG [64 h]; ELEC TECH [32 h]; MECH TECH [128 h]; SUPPLIES & MATERIALS | 11,712.57 | 11,462.59 |  |  |  |  | 11712.569775 |  | 0 | HOGAN J | 1 | 1 | S | JOHN H | 08-050 | 10-027 | 10-064 | 11-051 | 12-018F |  |  |  |  |  | 09-032 | 09-032 |  | 11-003 |  |  |  |  | ST | 09-017 |  |
| 1311132050 |  | Receive & Insp Waveguides 41 thru 48 |  | 3d | 2010-08-23 A | 2010-08-25 A | 1311132045, 1311131035 | 100% |  |  | MECH DES [12.8 h]; MECH ENG [25.6 h]; ELEC TECH [32 h]; MECH TECH [128 h]; SUPPLIES & MATERIALS | 9,183.93 | 8,933.95 |  |  |  |  | 9183.929775 |  | 0 | HOGAN J | 1 | 1 | S | JOHN H | 08-050 | 10-027 | 10-064 | 11-051 | 12-018F |  |  |  |  |  | 09-032 | 09-032 |  |  |  |  |  |  | ST | 09-017 |  |
| 1311132055 |  | Receive & Insp Waveguides 49 and 50 |  | 5d | 2010-09-01 A | 2010-09-08 A | 1311132050 | 100% |  |  | SUPPLIES & MATERIALS; MECH DES [3.2 h]; MECH ENG [6.4 h]; ELEC TECH [8 h]; MECH TECH [32 h] | 2,296.67 | 2,233.49 |  |  |  |  | 2296.671237 |  | 0 | HOGAN J | 1 | 1 | S | JOHN H | 08-050 | 10-027 | 10-064 | 11-051 | 12-018F |  |  |  |  |  | 09-032 | 09-032 |  |  |  |  |  |  | ST | 09-017 |  |
| 1311132060 |  | Receive & Insp Waveguides 51 thru 56 |  | 13d | 2010-09-09 A | 2010-09-27 A | 1311131040, 1311132055 | 100% |  |  | MECH DES [9.6 h]; MECH ENG [19.2 h]; ELEC TECH [24 h]; MECH TECH [96 h]; SUPPLIES & MATERIALS | 6,887.8 | 6,700.46 |  |  |  |  | 6887.805445 |  | 0 | HOGAN J | 1 | 1 | S | JOHN H | 08-050 | 10-027 | 10-064 | 11-051 | 12-018F |  |  |  |  |  | 09-032 | 09-032 |  |  |  |  |  |  | ST | 09-017 |  |
| 1311132065 |  | Receive & Insp Waveguides 57 thru 60 |  | 8d | 2010-12-10 A | 2010-12-23 A | 1311132060 | 100% | 2010-12-10 | 2010-12-21 | ELEC TECH [16 h]; MECH TECH [64 h]; SUPPLIES & MATERIALS; MECH DES [6.4 h]; MECH ENG [12.8 h] | 4,734.29 | 4,609.31 |  |  |  |  | 4591.959728 |  | 0 | HOGAN J | 1 | 1 | S | JOHN H | 08-050 | 10-027 | 10-064 | 11-051 | 12-018F |  |  |  |  |  | 09-032 | 09-032 |  |  |  |  |  |  | ST | 09-017 |  |
| 1311132070 |  | Receive & Insp Waveguides 61 thru 64 |  | 5d | 2011-01-10 A | 2011-01-17 A | 1311131045, 1311132065 | 100% | 2011-01-10 | 2011-01-14 | MECH DES [6.4 h]; MECH ENG [12.8 h]; ELEC TECH [16 h]; MECH TECH [64 h]; SUPPLIES & MATERIALS | 4,734.29 | 4,609.31 |  |  |  |  | 4591.959728 |  | 0 | HOGAN J | 1 | 1 | S | JOHN H | 08-050 | 10-027 | 10-064 | 11-051 | 12-018F |  |  |  |  |  | 09-032 | 09-032 |  |  |  |  |  |  | ST | 09-017 |  |
| 1311132075 |  | Receive & Insp Waveguides 65 thru 70 |  | 18.5d | 2011-02-01 A | 2011-02-28 A | 1311132070 | 100% |  |  | MECH TECH [96 h]; SUPPLIES & MATERIALS; MECH ENG [19.2 h]; MECH DES [9.6 h]; ELEC TECH [24 h] | 7,101.31 | 6,913.97 |  |  |  |  | 6887.805445 |  | 0 | HOGAN J | 1 | 1 | S | JOHN H | 08-050 | 10-027 | 10-064 | 11-051 | 12-018F |  |  |  |  |  | 09-032 | 09-032 |  |  |  |  |  |  | ST | 09-017 |  |
| 1311132080 |  | Receive & Insp Waveguides 71 and 72 |  | 13d | 2011-04-20 A | 2011-05-07 A | 1311131050, 1311132075 | 100% | 2011-04-20 | 2011-05-06 | SUPPLIES & MATERIALS; MECH DES [3.2 h]; ELEC TECH [8 h]; MECH TECH [32 h]; MECH ENG [6.4 h] | 2,367.84 | 2,304.66 |  |  |  |  | 2296.671237 |  | 0 | HOGAN J | 1 | 1 | S | JOHN H | 08-050 | 10-027 | 10-064 | 11-051 | 12-018F |  |  |  |  |  | 09-032 | 09-032 |  |  |  |  |  |  | ST | 09-017 |  |
| 1311132085 |  | Receive & Insp Waveguides 73 thru 80 |  | 10d | 2011-05-16 A | 2011-05-28 A | 1311132080 | 100% | 2011-05-16 | 2011-05-27 | MECH DES [12.8 h]; MECH ENG [25.6 h]; ELEC TECH [32 h]; MECH TECH [128 h]; SUPPLIES & MATERIALS | 9,468.6 | 9,218.62 |  |  |  |  | 9183.929775 |  | 0 | HOGAN J | 1 | 1 | S | JOHN H | 08-050 | 10-027 | 10-064 | 11-051 | 12-018F |  |  |  |  |  | 09-032 | 09-032 |  |  |  |  |  |  | ST | 09-017 |  |
| 1311132090 |  | Receive & Insp Waveguides 81 thru 88 |  | 15d | 2011-09-12 A | 2011-09-30 A | 1311131060, 1311132085, 1311131055 | 100% |  |  | MECH DES [16 h]; MECH ENG [32 h]; ELEC TECH [40 h]; MECH TECH [160 h]; SUPPLIES & MATERIALS | 11,781.23 | 11,523.28 |  |  |  |  | 11781.23 |  | 0 | HOGAN J | 1 | 1 | S | JOHN H | 08-050 | 10-027 | 10-064 | 11-051 | 12-018F |  |  |  |  |  | 09-032 | 09-032 |  |  |  |  |  |  | ST | 09-017 |  |
| 1311132100M |  | All Waveguides Received and Inspected | milestone | 0d | 2011-09-30 A | 2011-09-30 A | 1311132010, 1311132020, 1311132065, 1311132055, 1311132085, 1311132035, 1311132015, 1311131015LOEb, 1311132030, 1311132070, 1311132045, 1311132050, 1311132060, 1311132040, 1311132075, 1311132025, 1311132090, 1311132080 | 100% | 2011-11-01 | 2011-11-01 |  |  |  |  |  |  |  | 0 |  |  | HOGAN J | 1 | 1 | M | JOHN H | 08-050 | 10-027 | 10-064 | 11-051 | 12-018F |  |  |  |  |  | 09-032 | 09-032 |  |  |  |  |  |  |  | 09-017 | 07-024 |

Notes:
- 1311131015: Steps: Contract Prep (done); Vendor Selected (done); 1st Batch Waveguides Plated; Delivery of Waveguides 1-10
- 1311132010: Steps: Receive and Inspect Waveguide 1 (done); Receive and Inspect Waveguide 2 (done); Receive and Inspect Waveguide 3 (done); Receive and Inspect Waveguide 4 (done); Receive and Inspect Waveguide 5 (done); Receive and Inspect Waveguide 6 (done); Receive and Inspect Waveguide 7 (done); Receive and Inspect Waveguide 8 (done)
- 1311132015: Steps: Receive and Inspect Waveguide 9 (done); Receive and Inspect Waveguide 10 (done)
- 1311132020: Steps: Receive and Inspect Waveguide 11 (done); Receive and Inspect Waveguide 12 (done); Receive and Inspect Waveguide 13 (done); Receive and Inspect Waveguide 14 (done); Receive and Inspect Waveguide 15 (done); Receive and Inspect Waveguide 16 (done)
- 1311132025: Steps: Receive and Inspect Waveguide 17 (done); Receive and Inspect Waveguide 18 (done); Receive and Inspect Waveguide 19 (done); Receive and Inspect Waveguide 20 (done)
- 1311132030: Steps: Receive and Inspect Waveguide 21 (done); Receive and Inspect Waveguide 22 (done); Receive and Inspect Waveguide 23 (done); Receive and Inspect Waveguide 24 (done)
- 1311132035: Steps: Receive and Inspect Waveguide 25 (done); Receive and Inspect Waveguide 26 (done); Receive and Inspect Waveguide 27 (done); Receive and Inspect Waveguide 28 (done); Receive and Inspect Waveguide 29 (done); Receive and Inspect Waveguide 30 (done)
- 1311132040: Steps: Receive and Inspect Waveguide 31 (done); Receive and Inspect Waveguide 32 (done)
- 1311132045: Steps: Receive and Inspect Waveguide 33 (done); Receive and Inspect Waveguide 34 (done); Receive and Inspect Waveguide 35 (done); Receive and Inspect Waveguide 36 (done); Receive and Inspect Waveguide 37 (done); Receive and Inspect Waveguide 38 (done); Receive and Inspect Waveguide 39 (done); Receive and Inspect Waveguide 40 (done)
- 1311132050: Steps: Receive and Inspect Waveguide 41 (done); Receive and Inspect Waveguide 42 (done); Receive and Inspect Waveguide 43 (done); Receive and Inspect Waveguide 44 (done); Receive and Inspect Waveguide 45 (done); Receive and Inspect Waveguide 46 (done); Receive and Inspect Waveguide 47 (done); Receive and Inspect Waveguide 48 (done)
- 1311132055: Steps: Receive and Inspect Waveguide 49 (done); Receive and Inspect Waveguide 50 (done)
- 1311132060: Steps: Receive and Inspect Waveguide 51 (done); Receive and Inspect Waveguide 52 (done); Receive and Inspect Waveguide 53 (done); Receive and Inspect Waveguide 54 (done); Receive and Inspect Waveguide 55 (done); Receive and Inspect Waveguide 56 (done)
- 1311132065: Steps: Receive and Inspect Waveguide 57 (done); Receive and Inspect Waveguide 58 (done); Receive and Inspect Waveguide 59 (done); Receive and Inspect Waveguide 60 (done)
- 1311132070: Steps: Receive and Inspect Waveguide 61 (done); Receive and Inspect Waveguide 62 (done); Receive and Inspect Waveguide 63 (done); Receive and Inspect Waveguide 64 (done)
- 1311132075: Steps: Receive and Inspect Waveguide 65 (done); Receive and Inspect Waveguide 66 (done); Receive and Inspect Waveguide 67 (done); Receive and Inspect Waveguide 68 (done); Receive and Inspect Waveguide 69 (done); Receive and Inspect Waveguide 70 (done)
- 1311132080: Steps: Receive and Inspect Waveguide 71 (done); Receive and Inspect Waveguide 72 (done)
- 1311132085: Steps: Receive and Inspect Waveguide 73 (done); Receive and Inspect Waveguide 74 (done); Receive and Inspect Waveguide 75 (done); Receive and Inspect Waveguide 76 (done); Receive and Inspect Waveguide 77 (done); Receive and Inspect Waveguide 78 (done); Receive and Inspect Waveguide 79 (done); Receive and Inspect Waveguide 80 (done)
- 1311132090: Steps: Receive and Inspect Waveguide 81 (done); Receive and Inspect Waveguide 82 (done); Receive and Inspect Waveguide 83 (done); Receive and Inspect Waveguide 84 (done); Receive and Inspect Waveguide 85 (done); Receive and Inspect Waveguide 86 (done); Receive and Inspect Waveguide 87 (done); Receive and Inspect Waveguide 88 (done)

| ID | WBS | Activity | Type | Duration | Start | Finish | Predecessors | Complete | Planned start | Planned finish | Resources | Cost | Actual cost | Calculated Remaining Total Cost | MONTHLY EV COST | RESP - Responsibility | STRT%COMP for CM EVM | FNSH%COMP for CM EVM | EVMS Reporting Codes | CAM RESPONSIBLE | CR 08-050 | CR 08-052 | CR 09-017 | CR 10-027 | CR 10-064 | CR 11-003 | CR 11-051 | CR 12-018 | LOE Divider | LOE Multiplier | CR 07-024 | Advance Purchase Plan > 500K | CR 09-032 | CR 09-032 Repair | CR 10-001 | CR 09-012 | Remaining Material Cost Based on % Compl | Claimed Material Cost Based on % Complet | Initial Claimed Material Calc | Claimed Material Divider | Activities with Steps | CR 11-012 | ReBaseline Actuals Adjustment |
| --- | --- | --- | --- | --- | --- | --- | --- | --- | --- | --- | --- | --- | --- | --- | --- | --- | --- | --- | --- | --- | --- | --- | --- | --- | --- | --- | --- | --- | --- | --- | --- | --- | --- | --- | --- | --- | --- | --- | --- | --- | --- | --- | --- |
|  | 4 | **1.3.1.1.1.4 HELIUM VESSELS** |  |  | 2009-03-02 | 2013-08-30 |  |  |  |  |  |  |  |  |  |  |  |  |  |  |  |  |  |  |  |  |  |  |  |  |  |  |  |  |  |  |  |  |  |  |  |  |  |
| 131114010 |  | Proc Helium Vessels |  | 178d | 2009-03-02 A | 2009-11-09 A | 1211020M FS-42d, 9-090M | 100% |  |  | MECH ENG [20 h]; MECH DES [40 h] | 3,045.03 | 3,045.03 | 0 | 3029.8 | HOGAN J | 1 | 1 | H | JOHN H | 08-050 | 08-052 | 09-017 | 10-027 | 10-064 | 11-003 | 11-051 | 12-018F |  |  |  |  |  |  |  |  |  |  |  |  |  |  |  |
| 131114015LOE |  | Helium Vessels Labor Final FY09 |  | 63d | 2009-07-01 A | 2009-09-30 A | 131114015 | 100% | 2009-07-01 | 2009-09-29 | SUPPLIES & MATERIALS; TRAVEL; MECH ENG [34.23 h]; SR STAFF [11.41 h]; MECH DES [22.82 h] | 5,561.8 | 4,358.05 | 0 | 5561.7995 | HOGAN J | 1 | 1 | E | JOHN H | 08-050 |  | 09-017 | 10-027 | 10-064 | 11-003 | 11-051 | 12-018F | 100 | 100 | 07-024 | APP | 09-032 | 09-032 | 10-001B |  |  |  |  |  |  |  |  |
| 131114015 |  | Helium Vessels Labor Initial |  | 4d | 2009-09-21 A | 2009-09-24 A | 131114010 FS-125d | 100% |  |  | SUPPLIES & MATERIALS | 39.07 |  | 0 | 39.07 | HOGAN J | 1 | 1 | H | JOHN H | 08-050 |  | 09-017 | 10-027 | 10-064 | 11-003 | 11-051 | 12-018F |  |  | 07-024 | APP | 09-032 | 09-032 |  | 09-012 |  |  |  |  |  |  |  |
| 131114015LOEb |  | Helium Vessels Labor Final FY10 |  | 213d | 2009-10-01 A | 2010-08-11 A | 131114015LOE | 100% |  |  | MECH ENG [85.77 h]; SR STAFF [28.59 h]; MECH DES [57.18 h]; SUPPLIES & MATERIALS; TRAVEL | 14,381.43 | 11,268.74 | 0 | 14381.433574 | HOGAN J | 1 | 1 | E | JOHN H |  |  |  | 10-027 | 10-064 | 11-003 | 11-051 | 12-018F | 100 | 100 |  | APP |  |  | 10-001B |  |  |  |  |  |  |  |  |
| 131114016 |  | Vend Fab - Helium Vessels 1 & 2 |  | 168d | 2009-11-23 A | 2010-07-30 A | 131114010 | 100% |  |  | PROCUREMENT>$50K 69; PROCUREMENT<$50K 60 | 4,898.16 |  | 0 | 4898.16 | HOGAN J | 1 | 1 | D | JOHN H | 08-050 |  | 09-017 | 10-027 | 10-064 | 11-003 | 11-051 |  |  |  | 07-024 | APP | 09-032 | 09-032 |  | 09-012 | 0 | 4898.16 | 489816 | 100 | NB | 11-012 |  |
| 131114017 |  | Vend Fab - Helium Vessels 3 Thru 8 |  | 168d | 2009-11-23 A | 2010-07-30 A | 131114010 | 100% |  |  | PROCUREMENT>$50K 69; PROCUREMENT<$50K 60 | 14,694.48 |  | 0 | 14694.48 | HOGAN J | 1 | 1 | D | JOHN H | 08-050 |  | 09-017 | 10-027 | 10-064 | 11-003 | 11-051 |  |  |  | 07-024 | APP | 09-032 | 09-032 |  |  | 0 | 14694.48 | 1469448 | 100 | NB | 11-012 |  |
| 131114020 |  | Vend Fab - Helium Vessels 9 Thru 16 |  | 223d | 2009-11-23 A | 2010-10-18 A | 131114017 FS-500d, 131114010 | 100% |  |  | PROCUREMENT>$50K 69; PROCUREMENT<$50K 60 | 19,592.64 |  | 0 | 19592.64 | HOGAN J | 1 | 1 | D | JOHN H | 08-050 |  | 09-017 | 10-027 | 10-064 | 11-003 | 11-051 |  |  |  | 07-024 |  | 09-032 | 09-032 |  |  | 0 | 19592.64 | 1959264 | 100 | NB | 11-012 |  |
| 131114025 |  | Vend Fab - Helium Vessels 17 Thru 24 |  | 267d | 2009-11-23 A | 2010-12-23 A | 131114010, 131114020 FS-500d | 100% | 2009-11-23 | 2010-12-21 | PROCUREMENT<$50K 60 NO ESCALATION FY10; PROCUREMENT>$50K 69 NO ESCALATION FY10 | 19,592.64 |  | 0 | 19592.64 | HOGAN J | 1 | 1 | D | JOHN H | 08-050 |  | 09-017 | 10-027 | 10-064 |  | 11-051 | 12-018F |  |  | 07-024 |  | 09-032 | 09-032 |  |  | 0 | 19592.64 | 1959264 | 100 | NB | 11-012 |  |
| 131114030 |  | Vend Fab - Helium Vessels 25 Thru 32 |  | 279d | 2009-11-23 A | 2011-01-14 A | 131114025 FS-500d, 131114010 | 100% |  |  | PROCUREMENT<$50K 60 NO ESCALATION FY10; PROCUREMENT>$50K 69 NO ESCALATION FY10 | 19,592.64 |  | 0 | 19592.64 | HOGAN J | 1 | 1 | D | JOHN H | 08-050 |  | 09-017 | 10-027 | 10-064 | 11-003 | 11-051 | 12-018F |  |  | 07-024 |  | 09-032 | 09-032 |  |  | 0 | 19592.64 | 1959264 | 100 | NB | 11-012 |  |
| 131114035 |  | Vend Fab - Helium Vessels 33 Thru 40 |  | 308d | 2009-11-23 A | 2011-02-28 A | 131114030 FS-500d, 131114010 | 100% |  |  | PROCUREMENT>$50K 69 NO ESCALATION FY10; PROCUREMENT<$50K 60 NO ESCALATION FY10 | 19,592.64 |  | 0 | 19592.64 | HOGAN J | 1 | 1 | D | JOHN H | 08-050 |  | 09-017 | 10-027 | 10-064 | 11-003 | 11-051 | 12-018F |  |  | 07-024 |  | 09-032 | 09-032 |  |  | 0 | 19592.64 | 1959264 | 100 | NB | 11-012 |  |
| 131114040 |  | Vend Fab - Helium Vessels 41 Thru 48 |  | 308d | 2009-11-23 A | 2011-02-28 A | 131114010, 131114035 FS-500d | 100% |  |  | PROCUREMENT<$50K 60 NO ESCALATION FY10; PROCUREMENT>$50K 69 NO ESCALATION FY10 | 19,592.64 |  | 0 | 19592.64 | HOGAN J | 1 | 1 | D | JOHN H | 08-050 |  | 09-017 | 10-027 | 10-064 | 11-003 | 11-051 | 12-018F |  |  | 07-024 |  | 09-032 | 09-032 |  |  | 0 | 19592.64 | 1959264 | 100 | NB | 11-012 |  |
| 131114045 |  | Vend Fab - Helium Vessels 49 Thru 56 |  | 328d | 2009-11-23 A | 2011-03-28 A | 131114010, 131114040 FS-500d | 100% |  |  | PROCUREMENT>$50K 69 NO ESCALATION FY10; PROCUREMENT<$50K 60 NO ESCALATION FY10 | 19,592.64 |  | 0 | 19592.64 | HOGAN J | 1 | 1 | D | JOHN H | 08-050 |  | 09-017 | 10-027 | 10-064 | 11-003 | 11-051 | 12-018F |  |  | 07-024 |  | 09-032 | 09-032 |  |  | 0 | 19592.64 | 1959264 | 100 | NB | 11-012 |  |
| 131114050 |  | Vend Fab - Helium Vessels 57 Thru 64 |  | 348d | 2009-11-23 A | 2011-04-25 A | 131114010, 131114045 FS-500d | 100% |  |  | PROCUREMENT<$50K 60 NO ESCALATION FY10; PROCUREMENT>$50K 69 NO ESCALATION FY10 | 19,592.64 |  | 0 | 19592.64 | HOGAN J | 1 | 1 | D | JOHN H | 08-050 |  | 09-017 | 10-027 | 10-064 | 11-003 | 11-051 | 12-018F |  |  | 07-024 |  | 09-032 | 09-032 |  |  | 0 | 19592.64 | 1959264 | 100 | NB | 11-012 |  |
| 131114055 |  | Vend Fab - Helium Vessels 65 Thru 72 |  | 348d | 2009-11-23 A | 2011-04-25 A | 131114050 FS-500d, 131114010 | 100% |  |  | PROCUREMENT<$50K 60 NO ESCALATION FY10; PROCUREMENT>$50K 69 NO ESCALATION FY10 | 19,592.64 |  | 0 | 19592.64 | HOGAN J | 1 | 1 | D | JOHN H | 08-050 |  | 09-017 | 10-027 | 10-064 | 11-003 | 11-051 | 12-018F |  |  | 07-024 |  | 09-032 | 09-032 |  |  | 0 | 19592.64 | 1959264 | 100 | NB |  |  |
| 131114060 |  | Vend Fab - Helium Vessels 73 Thru 80 |  | 368d | 2009-11-23 A | 2011-05-23 A | 131114055 FS-500d, 131114010 | 100% |  |  | PROCUREMENT>$50K 69 NO ESCALATION FY10; PROCUREMENT<$50K 60 NO ESCALATION FY10 | 19,592.64 |  | 0 | 19592.64 | HOGAN J | 1 | 1 | D | JOHN H | 08-050 |  | 09-017 | 10-027 | 10-064 | 11-003 | 11-051 | 12-018F |  |  | 07-024 |  | 09-032 | 09-032 |  |  | 0 | 19592.64 | 1959264 | 100 | NB |  |  |
| 131114065 |  | Vend Fab - Helium Vessels 81 Thru 90 |  | 387d | 2009-11-23 A | 2011-06-20 A | 131114010, 131114060 FS-500d | 100% |  |  | PROCUREMENT<$50K 60 NO ESCALATION FY10; PROCUREMENT>$50K 69 NO ESCALATION FY10 | 24,490.81 |  | 0 | 24490.81 | HOGAN J | 1 | 1 | D | JOHN H | 08-050 |  | 09-017 | 10-027 | 10-064 | 11-003 | 11-051 | 12-018F |  |  | 07-024 | APP | 09-032 | 09-032 | 10-001A |  | 0 | 24490.81 | 2449081 | 100 | NB |  |  |
| 131114070 |  | Receive & Insp Helium Vessels 1 & 2 |  | 29d | 2010-06-15 A | 2010-07-26 A | 131114016 | 100% |  |  | MECH ENG [8 h]; MECH TECH [12 h]; MECH DES [8 h]; SUPPLIES & MATERIALS | 1,602.52 | 1,389.6 | 0 | 1559.52 | HOGAN J | 1 | 1 | S | JOHN H | 08-050 |  | 09-017 | 10-027 | 10-064 | 11-003 | 11-051 |  |  |  | 07-024 |  | 09-032 | 09-032 |  |  |  |  |  |  | ST | 11-012 |  |
| 131114130 |  | Vend Fab 10 CFR 851 Compliance |  | 250d | 2010-07-01 A | 2011-07-05 A | 131114010 FS+120d | 100% |  |  | PROCUREMENT>$50K 69 NO ESCALATION FY11 | 275,000 |  | 0 | 275000 | HOGAN J | 1 | 1 | D | JOHN H |  |  |  |  | 10-064 | 11-003 | 11-051 | 12-018F |  |  |  | APP |  |  |  |  | 0 | 275000 | 27500000 | 100 |  |  |  |
| 131114075 |  | Receive & Insp Helium Vessels 3 Thru 8 |  | 10d | 2010-07-19 A | 2010-07-30 A | 131114070, 131114017 | 100% |  |  | MECH DES [24 h]; SUPPLIES & MATERIALS; MECH ENG [24 h]; MECH TECH [36 h] | 4,488.25 | 4,168.8 | 0 | 4359.25 | HOGAN J | 1 | 1 | S | JOHN H | 08-050 |  | 09-017 | 10-027 | 10-064 | 11-003 | 11-051 |  |  |  | 07-024 |  | 09-032 | 09-032 |  |  |  |  |  |  | ST | 11-012 |  |
| 131114015LOEc |  | SOTR Oversight FY11 |  | 116d | 2010-10-01 A | 2011-03-25 A | 9-110M, 131114015LOEb | 100% |  |  | MECH ENG [100 h] | 6,795 | 6,795 | 0 | 6795 | HOGAN J | 1 | 1 | E | JOHN H |  |  |  |  | 10-064 | 11-003 | 11-051 | 12-018F | 100 | 100 |  |  |  |  |  |  |  |  |  |  |  |  |  |
| 131114080 |  | Receive & Insp Helium Vessels 9 Thru 16 |  | 12d | 2010-10-01 A | 2010-10-18 A | 131114075, 131114020 | 100% |  |  | SUPPLIES & MATERIALS; MECH DES [17.6 h]; MECH ENG [32 h]; MECH TECH [48 h] | 5,489.26 | 5,063.33 | 0 | 5181.034 | HOGAN J | 1 | 1 | S | JOHN H | 08-050 |  | 09-017 | 10-027 | 10-064 | 11-003 | 11-051 |  |  |  | 07-024 |  | 09-032 | 09-032 |  |  |  |  |  |  | ST | 11-012 |  |
| 131114085 |  | Receive & Insp Helium Vessels 17 thru 24 |  | 6d | 2011-01-04 A | 2011-01-11 A | 131114025, 131114080 | 100% |  |  | MECH ENG [20.8 h]; SUPPLIES & MATERIALS; MECH DES [12.8 h]; MECH TECH [48 h] | 4,517.74 | 4,078.22 | 0 | 4391.789167 | HOGAN J | 1 | 1 | S | JOHN H | 08-050 |  | 09-017 | 10-027 | 10-064 |  | 11-051 | 12-018F |  |  | 07-024 |  | 09-032 | 09-032 |  |  |  |  |  |  | ST | 11-012 |  |
| 131114090 |  | Receive & Insp Helium Vessels 25 Thru 32 |  | 19d | 2011-02-01 A | 2011-02-28 A | 131114085, 131114030 | 100% |  |  | MECH ENG [21.81 h]; SUPPLIES & MATERIALS; MECH DES [12.8 h]; MECH TECH [48 h] | 4,586.37 | 4,146.85 | 0 | 4458.297667 | HOGAN J | 1 | 1 | S | JOHN H | 08-050 |  | 09-017 | 10-027 | 10-064 | 11-003 | 11-051 | 12-018F |  |  | 07-024 |  | 09-032 | 09-032 |  |  |  |  |  |  | ST | 11-012 |  |
| 131114095 |  | Receive & Insp Helium Vessels 33 Thru 40 |  | 19d | 2011-02-01 A | 2011-02-28 A | 131114090, 131114035 | 100% |  |  | MECH DES [12.8 h]; MECH ENG [9.6 h]; SUPPLIES & MATERIALS; MECH TECH [48 h] | 3,756.7 | 3,317.18 | 0 | 3654.269167 | HOGAN J | 1 | 1 | S | JOHN H | 08-050 |  | 09-017 | 10-027 | 10-064 | 11-003 | 11-051 | 12-018F |  |  | 07-024 |  | 09-032 | 09-032 |  |  |  |  |  |  | ST | 11-012 |  |
| 131114100 |  | Receive & Insp Helium Vessels 41 thru 48 |  | 15d | 2011-03-01 A | 2011-03-21 A | 131114095, 131114040 | 100% |  |  | SUPPLIES & MATERIALS; MECH TECH [48 h]; MECH DES [12.8 h]; MECH ENG [9.6 h] | 3,756.7 | 3,317.18 | 0 | 3654.269167 | HOGAN J | 1 | 1 | S | JOHN H | 08-050 |  | 09-017 | 10-027 | 10-064 | 11-003 | 11-051 | 12-018F |  |  | 07-024 |  | 09-032 | 09-032 |  |  |  |  |  |  | ST | 11-012 |  |
| 131114105 |  | Receive & Insp Helium Vessels 49 Thru 56 |  | 15d | 2011-03-01 A | 2011-03-21 A | 131114045, 131114100 | 100% |  |  | MECH DES [12.8 h]; MECH ENG [9.6 h]; SUPPLIES & MATERIALS; MECH TECH [48 h] | 3,756.7 | 3,317.18 | 0 | 3654.269167 | HOGAN J | 1 | 1 | S | JOHN H | 08-050 |  | 09-017 | 10-027 | 10-064 | 11-003 | 11-051 | 12-018F |  |  | 07-024 |  | 09-032 | 09-032 |  |  |  |  |  |  | ST | 11-012 |  |
| 131114110 |  | Receive & Insp Helium Vessels 57 Thru 64 |  | 12d | 2011-04-01 A | 2011-04-18 A | 131114050, 131114105 | 100% |  |  | SUPPLIES & MATERIALS; MECH DES [12.8 h]; MECH TECH [48 h]; MECH ENG [9.6 h] | 3,756.7 | 3,317.18 | 0 | 3654.269167 | HOGAN J | 1 | 1 | S | JOHN H | 08-050 |  | 09-017 | 10-027 | 10-064 | 11-003 | 11-051 | 12-018F |  |  | 07-024 |  | 09-032 | 09-032 |  |  |  |  |  |  | ST | 11-012 |  |
| 131114115 |  | Receive & Insp Helium Vessels 65 thru 72 |  | 5d | 2011-05-02 A | 2011-05-07 A | 131114110, 131114055 | 100% | 2011-05-02 | 2011-05-06 | MECH DES [12.8 h]; MECH ENG [9.6 h]; SUPPLIES & MATERIALS; MECH TECH [48 h] | 3,756.7 | 3,317.18 | 0 | 3654.269167 | HOGAN J | 1 | 1 | S | JOHN H | 08-050 |  | 09-017 | 10-027 | 10-064 | 11-003 | 11-051 | 12-018F |  |  | 07-024 |  | 09-032 | 09-032 |  |  |  |  |  |  | ST |  |  |
| 131114120 |  | Receive & Insp Helium Vessels 73 thru 80 |  | 6d | 2011-05-08 A | 2011-05-16 A | 131114115, 131114060 | 100% | 2011-05-09 | 2011-05-16 | MECH DES [12.8 h]; MECH ENG [9.6 h]; SUPPLIES & MATERIALS; MECH TECH [48 h] | 3,756.7 | 3,317.18 | 0 | 3654.269167 | HOGAN J | 1 | 1 | S | JOHN H | 08-050 |  | 09-017 | 10-027 | 10-064 | 11-003 | 11-051 | 12-018F |  |  | 07-024 |  | 09-032 | 09-032 |  |  |  |  |  |  | ST |  |  |
| 131114125 |  | Receive & Insp Helium Vessels 81 Thru 90 |  | 2d | 2011-07-01 A | 2011-07-05 A | 131114065, 131114120 | 100% |  |  | MECH TECH [48 h]; MECH DES [12.8 h]; MECH ENG [9.6 h]; SUPPLIES & MATERIALS | 3,756.7 | 3,317.18 | 0 | 3654.269167 | HOGAN J | 1 | 1 | S | JOHN H | 08-050 |  | 09-017 | 10-027 | 10-064 | 11-003 | 11-051 | 12-018F |  |  | 07-024 |  | 09-032 | 09-032 |  |  |  |  |  |  | ST |  |  |
| 131114130M |  | All Helium Vessels Received and Inspected | milestone | 0d | 2011-07-05 A | 2011-07-05 A | 131114095, 131114090, 131114070, 131114075, 131114085, 131114115, 131114110, 131114130, 131114015LOEc, 131114120, 131114105, 131114015LOEb, 131114125, 131114100, 131114080 | 100% | 2011-08-05 | 2011-08-05 |  |  |  |  | 0 | HOGAN J | 1 | 1 | M | JOHN H | 08-050 |  | 09-017 | 10-027 | 10-064 | 11-003 | 11-051 | 12-018F |  |  | 07-024 |  | 09-032 | 09-032 |  |  |  |  |  |  |  |  |  |
| 131114135 |  | Re-Baseline Actuals Adjustment |  | 1d | 2013-08-30 A | 2013-08-30 A |  | 100% | 2013-09-03 | 2013-09-03 | PROCUREMENT>$50K 69 NO ESCALATION | 85,759.34 |  |  | 85759.34 |  |  |  |  |  |  |  |  |  |  |  |  |  |  |  |  |  |  |  |  |  | 0 | 85759.34 | 8575934 | 100 |  |  | ADJ |

Notes:
- 131114016: Explanation: Contract Finish Date 7/16/2010
- 131114017: Explanation: Contract Finish Date 7/16/2010
- 131114020: Explanation: Contract Finish Date 8/20/2010
- 131114025: Explanation: Contract Finish Date 9/28/2010
- 131114030: Explanation: Contract Finish Date 10/28/2010
- 131114035: Explanation: Contract Finish Date 10/28/2010
- 131114040: Explanation: Contract Finish Date 12/6/2010
- 131114045: Explanation: Contract Finish Date 1/7/2011
- 131114050: Explanation: Contract Finish Date 2/15/2011
- 131114055: Explanation: Contract Finish Date 3/14/2011
- 131114060: Explanation: Contract Finish Date 3/14/2011
- 131114065: Explanation: Contract Finish Date 4/13/2011
- 131114070: Steps: Receive and Inspect Helium Vessel 1 (done); Receive and Inspect Helium Vessel 2 (done)
- 131114075: Steps: Receive and Inspect Helium Vessel 3 (done); Receive and Inspect Helium Vessel 4 (done); Receive and Inspect Helium Vessel 5 (done); Receive and Inspect Helium Vessel 6 (done); Receive and Inspect Helium Vessel 7 (done); Receive and Inspect Helium Vessel 8 (done)
- 131114080: Steps: Receive and Inspect Helium Vessel 9 (done); Receive and Inspect Helium Vessel 10 (done); Receive and Inspect Helium Vessel 11 (done); Receive and Inspect Helium Vessel 12 (done); Receive and Inspect Helium Vessel 13 (done); Receive and Inspect Helium Vessel 14 (done); Receive and Inspect Helium Vessel 15 (done); Receive and Inspect Helium Vessel 16 (done)
- 131114085: Steps: Receive and Inspect Helium Vessel 17 (done); Receive and Inspect Helium Vessel 18 (done); Receive and Inspect Helium Vessel 19 (done); Receive and Inspect Helium Vessel 20 (done); Receive and Inspect Helium Vessel 21 (done); Receive and Inspect Helium Vessel 22 (done); Receive and Inspect Helium Vessel 23 (done); Receive and Inspect Helium Vessel 24 (done)
- 131114090: Steps: Receive and Inspect Helium Vessel 25 (done); Receive and Inspect Helium Vessel 26 (done); Receive and Inspect Helium Vessel 27 (done); Receive and Inspect Helium Vessel 28 (done); Receive and Inspect Helium Vessel 29 (done); Receive and Inspect Helium Vessel 30 (done); Receive and Inspect Helium Vessel 31 (done); Receive and Inspect Helium Vessel 32 (done)
- 131114095: Steps: Receive and Inspect Helium Vessel 33 (done); Receive and Inspect Helium Vessel 34 (done); Receive and Inspect Helium Vessel 35 (done); Receive and Inspect Helium Vessel 36 (done); Receive and Inspect Helium Vessel 37 (done); Receive and Inspect Helium Vessel 38 (done); Receive and Inspect Helium Vessel 39 (done); Receive and Inspect Helium Vessel 40 (done)
- 131114100: Steps: Receive and Inspect Helium Vessel 41 (done); Receive and Inspect Helium Vessel 42 (done); Receive and Inspect Helium Vessel 43 (done); Receive and Inspect Helium Vessel 44 (done); Receive and Inspect Helium Vessel 45 (done); Receive and Inspect Helium Vessel 46 (done); Receive and Inspect Helium Vessel 47 (done); Receive and Inspect Helium Vessel 48 (done)
- 131114105: Steps: Receive and Inspect Helium Vessel 49 (done); Receive and Inspect Helium Vessel 50 (done); Receive and Inspect Helium Vessel 51 (done); Receive and Inspect Helium Vessel 52 (done); Receive and Inspect Helium Vessel 53 (done); Receive and Inspect Helium Vessel 54 (done); Receive and Inspect Helium Vessel 55 (done); Receive and Inspect Helium Vessel 56 (done)
- 131114110: Steps: Receive and Inspect Helium Vessel 57 (done); Receive and Inspect Helium Vessel 58 (done); Receive and Inspect Helium Vessel 59 (done); Receive and Inspect Helium Vessel 60 (done); Receive and Inspect Helium Vessel 61 (done); Receive and Inspect Helium Vessel 62 (done); Receive and Inspect Helium Vessel 63 (done); Receive and Inspect Helium Vessel 64 (done)
- 131114115: Steps: Receive and Inspect Helium Vessel 65 (done); Receive and Inspect Helium Vessel 66 (done); Receive and Inspect Helium Vessel 67 (done); Receive and Inspect Helium Vessel 68 (done); Receive and Inspect Helium Vessel 69 (done); Receive and Inspect Helium Vessel 70 (done); Receive and Inspect Helium Vessel 71 (done); Receive and Inspect Helium Vessel 72 (done)
- 131114120: Steps: Receive and Inspect Helium Vessel 73 (done); Receive and Inspect Helium Vessel 74 (done); Receive and Inspect Helium Vessel 75 (done); Receive and Inspect Helium Vessel 76 (done); Receive and Inspect Helium Vessel 77 (done); Receive and Inspect Helium Vessel 78 (done); Receive and Inspect Helium Vessel 79 (done); Receive and Inspect Helium Vessel 80 (done)
- 131114125: Steps: Receive and Inspect Helium Vessel 81 (done); Receive and Inspect Helium Vessel 82 (done); Receive and Inspect Helium Vessel 83 (done); Receive and Inspect Helium Vessel 84 (done); Receive and Inspect Helium Vessel 85 (done); Receive and Inspect Helium Vessel 86 (done); Receive and Inspect Helium Vessel 87 (done); Receive and Inspect Helium Vessel 88 (done); Receive and Inspect Helium Vessel 89 (done); Receive and Inspect Helium Vessel 90 (done)

| ID | WBS | Activity | Duration | Start | Finish | Predecessors | Complete | Planned start | Planned finish | Resources | Cost | Actual cost | Calculated Remaining Total Cost | MONTHLY EV COST | RESP - Responsibility | STRT%COMP for CM EVM | FNSH%COMP for CM EVM | EVMS Reporting Codes | CAM RESPONSIBLE | CR 08-050 | CR 10-027 | CR 10-064 | CR 11-003 | CR 11-051 | Remaining Material Cost Based on % Compl | Claimed Material Cost Based on % Complet | Initial Claimed Material Calc | Claimed Material Divider | CR 07-024 | CR 07-027 | CR 09-017 | CR 12-018 | ReBaseline Actuals Adjustment | Profile change | CR 10-001 | LOE Divider | LOE Multiplier | CR 10-031 | CR 10-065 | CR 10-066 | CR 08-052 | 12 GEV MAJOR PROCUREMENT CATAGORY | CR 09-048 | CR 12-028 | Advance Purchase Plan > 500K | CR 09-012 | CR 11-012 | LOE % Pre Calc | LOE % |
| --- | --- | --- | --- | --- | --- | --- | --- | --- | --- | --- | --- | --- | --- | --- | --- | --- | --- | --- | --- | --- | --- | --- | --- | --- | --- | --- | --- | --- | --- | --- | --- | --- | --- | --- | --- | --- | --- | --- | --- | --- | --- | --- | --- | --- | --- | --- | --- | --- | --- |
|  | 5 | **1.3.1.1.1.5 HARDWARE** |  | 2009-09-01 | 2013-08-30 |  |  |  |  |  |  |  |  |  |  |  |  |  |  |  |  |  |  |  |  |  |  |  |  |  |  |  |  |  |  |  |  |  |  |  |  |  |  |  |  |  |  |  |  |
| 131115010 |  | Proc Hardware | 265d | 2009-09-01 A | 2010-09-24 A | 9-090M FS+98d | 100% |  |  | MECH DES [40 h]; MECH ENG [40 h] | 4,432.69 | 4,432.69 | 0 | 4306 | HOGAN J | 1 | 1 | H | JOHN H | 08-050 | 10-027 | 10-064 | 11-003 | 11-051 |  |  |  |  |  |  |  |  |  |  |  |  |  |  |  |  |  |  |  |  |  |  |  |  |  |
| 131115012 |  | Vend Fab - Hardware (Phase 1) | 33d | 2009-12-28 A | 2010-02-15 A | 131115010 FS-250d | 100% | 2009-12-28 | 2010-02-12 | PROCUREMENT<$50K 60; MECH DES [20 h]; MECH ENG [20 h]; MECH TECH [20 h] | 21,690.91 | 3,056.6 | 0 | 21596.308175 | HOGAN J | 1 | 1 | H | JOHN H | 08-050 | 10-027 | 10-064 | 11-003 | 11-051 | 0 | 18634.31 | 1863431 | 100 | 07-024 | 07-027 |  |  |  |  |  |  |  |  |  |  |  |  |  |  |  |  |  |  |  |
| 131115013 |  | Vend Fab - Hardware (Phase 2) | 161d | 2010-02-08 A | 2010-09-24 A | 131115012 | 100% |  |  | PROCUREMENT<$50K 60; MECH DES [20 h]; MECH ENG [20 h]; MECH TECH [20 h] | 21,690.91 | 3,056.6 | 0 | 21596.308175 | HOGAN J | 1 | 1 | H | JOHN H | 08-050 | 10-027 | 10-064 | 11-003 | 11-051 | 0 | 18634.31 | 1863431 | 100 | 07-024 | 07-027 | 09-017 | 12-018F |  |  |  |  |  |  |  |  |  |  |  |  |  |  |  |  |  |
| 131115015 |  | Receive & Insp Hardware (Phase 1) | 3d | 2010-05-24 A | 2010-05-26 A | 131115012 FS+10d, 131115010 | 100% |  |  | MECH ENG [20 h]; MECH TECH [40 h]; MECH DES [20 h] | 3,891.4 | 3,891.4 | 0 | 3771 | HOGAN J | 1 | 1 | U | JOHN H | 08-050 | 10-027 | 10-064 | 11-003 | 11-051 |  |  |  |  |  |  | 09-017 |  |  |  |  |  |  |  |  |  |  |  |  |  |  |  |  |  |  |
| 131115016 |  | Receive & Insp Hardware (Phase 2) | 12d | 2010-09-13 A | 2010-09-28 A | 131115013 | 100% |  |  | MECH DES [20 h]; MECH ENG [20 h]; MECH TECH [40 h] | 3,891.4 | 3,891.4 | 0 | 3771 | HOGAN J | 1 | 1 | U | JOHN H | 08-050 | 10-027 | 10-064 | 11-003 | 11-051 |  |  |  |  |  |  | 09-017 | 12-018F |  |  |  |  |  |  |  |  |  |  |  |  |  |  |  |  |  |
| 131115020 |  | Re-Baseline Actuals Adjustment | 1d | 2013-08-30 A | 2013-08-30 A |  | 100% | 2013-09-03 | 2013-09-03 | PROCUREMENT>$50K 69 NO ESCALATION | 67,377.96 |  |  | 67377.96 |  |  |  |  |  |  |  |  |  |  | 0 | 67377.96 | 6737796 | 100 |  |  |  |  | ADJ |  |  |  |  |  |  |  |  |  |  |  |  |  |  |  |  |
|  | 6 | **1.3.1.1.1.6 MISC** |  | 2009-09-01 | 2013-08-30 |  |  |  |  |  |  |  |  |  |  |  |  |  |  |  |  |  |  |  |  |  |  |  |  |  |  |  |  |  |  |  |  |  |  |  |  |  |  |  |  |  |  |  |  |
| 131116010 |  | Proc Misc | 269d | 2009-09-01 A | 2010-09-30 A | 121114010M FS-132d, 9-090M FS+108d | 100% |  |  | MECH TECH [40 h]; MECH DES [40 h]; MECH ENG [16 h] | 4,521.85 | 4,521.85 | 0 | 4392.56 | HOGAN J | 1 | 1 | H | JOHN H | 08-050 | 10-027 | 10-064 | 11-003 | 11-051 |  |  |  |  |  |  |  |  |  | C |  |  |  |  |  |  |  |  |  |  |  |  |  |  |  |
| 131116012 |  | Vend Fab - Misc (Phase 1) | 14d | 2009-12-21 A | 2010-01-18 A | 131116010 FS-200d | 100% | 2009-12-28 | 2010-01-15 | SUPPLIES & MATERIALS; MECH TECH [20 h]; MECH DES [20 h]; MECH ENG [20 h]; PROCUREMENT<$50K 60 | 27,547.41 | 3,056.6 | 0 | 27452.80503 | HOGAN J | 1 | 1 | H | JOHN H | 08-050 | 10-027 | 10-064 | 11-003 | 11-051 | 0 | 23958.4 | 2395840 | 100 |  |  |  |  |  |  |  |  |  |  |  |  |  |  |  |  |  |  |  |  |  |
| 131116013 |  | Vend Fab - Misc (Phase 2) Labor FY09 | 193d | 2009-12-21 A | 2010-09-30 A | 131116012 FS-200d | 100% | 2009-12-28 | 2010-09-30 | MECH DES [13.73 h]; MECH ENG [13.73 h]; SUPPLIES & MATERIALS; MECH TECH [13.73 h] | 2,463.74 | 2,098.36 | 0 | 2398.793 | HOGAN J | 1 | 1 | H | JOHN H | 08-050 | 10-027 | 10-064 | 11-003 | 11-051 |  |  |  |  |  |  | 09-017 | 12-018F |  |  | 10-001B |  |  |  |  |  |  |  |  |  |  |  |  |  |  |
| 131116013b |  | Vend Fab - Misc (Phase 2) Labor FY10 | 193d | 2009-12-21 A | 2010-09-30 A | 131116013 FS-200d | 100% | 2009-12-28 | 2010-09-30 | SUPPLIES & MATERIALS; MECH TECH [6.27 h]; MECH DES [6.27 h]; MECH ENG [6.27 h] | 1,130.6 | 958.24 | 0 | 1130.602357 | HOGAN J | 1 | 1 | H | JOHN H |  | 10-027 | 10-064 | 11-003 | 11-051 |  |  |  |  |  |  |  | 12-018F |  |  | 10-001B |  |  |  |  |  |  |  |  |  |  |  |  |  |  |
| 131116013c |  | Vend Fab - Misc (Phase 2) Procurement | 165d | 2010-02-08 A | 2010-09-30 A | 131116012 | 100% |  |  | PROCUREMENT<$50K 60 NO ESCALATION FY10 | 23,958.4 |  | 0 | 23958.4 | HOGAN J | 1 | 1 | H | JOHN H |  | 10-027 | 10-064 | 11-003 | 11-051 | 0 | 23958.4 | 2395840 | 100 |  |  |  | 12-018F |  |  | 10-001B |  |  |  |  |  |  |  |  |  |  |  |  |  |  |
| 131116020 |  | QC Traveler FY10 | 128d | 2010-04-01 A | 2010-09-30 A | 9-100M FS+120d | 100% |  |  | COMP SCIENT [40 h]; MECH ENG [560 h]; MECH TECH [342.4 h] | 53,632.58 | 53,632.58 | 0 | 53632.576 | HOGAN J | 1 | 1 | E | JOHN H |  | 10-027 | 10-064 |  |  |  |  |  |  |  |  |  |  |  |  |  | 100 | 100 | 10-031 | 10-065 | 10-066 |  |  |  |  |  |  |  |  |  |
| 131116015 |  | Receive & Insp Misc (Phase 1) | 4d | 2010-05-24 A | 2010-05-27 A | 131116010, 131116012 | 100% |  |  | MECH ENG [20 h]; MECH TECH [40 h]; MECH DES [20 h] | 3,891.4 | 3,891.4 | 0 | 3771 | HOGAN J | 1 | 1 | U | JOHN H | 08-050 | 10-027 | 10-064 | 11-003 | 11-051 |  |  |  |  |  |  | 09-017 |  |  |  |  |  |  |  |  |  |  |  |  |  |  |  |  |  |  |
| 131116016 |  | Receive & Insp Misc (Phase 2) | 109d | 2010-09-15 A | 2011-02-28 A | 131116013c, 131116013b | 100% |  |  | MECH TECH [40 h]; MECH DES [20 h]; MECH ENG [20 h] | 4,001.75 | 4,001.75 | 0 | 3891.4 | HOGAN J | 1 | 1 | U | JOHN H | 08-050 | 10-027 | 10-064 | 11-003 | 11-051 |  |  |  |  |  |  | 09-017 | 12-018F |  |  |  |  |  |  |  |  |  |  |  |  |  |  |  |  |  |
| 131116025 |  | QC Traveler FY11 | 58d | 2010-10-01 A | 2010-12-30 A | 131116020 | 100% |  |  | MECH ENG [400 h]; MECH TECH [400 h]; COMP SCIENT [120 h] | 52,038.8 | 52,038.8 | 0 | 52038.8 | HOGAN J | 1 | 1 | E | JOHN H |  | 10-027 | 10-064 |  |  |  |  |  |  |  |  |  |  |  |  |  | 100 | 100 | 10-031 | 10-065 | 10-066 |  |  |  |  |  |  |  |  |  |
| 131116030 |  | Re-Baseline Actuals Adjustment | 1d | 2013-08-30 A | 2013-08-30 A |  | 100% | 2013-09-03 | 2013-09-03 | PROCUREMENT>$50K 69 NO ESCALATION | 292,678.85 |  |  | 292678.85 |  |  |  |  |  |  |  |  |  |  | 0 | 292678.85 | 29267885 | 100 |  |  |  |  | ADJ |  |  |  |  |  |  |  |  |  |  |  |  |  |  |  |  |
|  | 2 | **1.3.1.1.2 SPACE FRAME PROCUREMENTS** |  | 2009-02-02 | 2013-08-30 |  |  |  |  |  |  |  |  |  |  |  |  |  |  |  |  |  |  |  |  |  |  |  |  |  |  |  |  |  |  |  |  |  |  |  |  |  |  |  |  |  |  |  |  |
|  | 1 | **1.3.1.1.2.1 SPACE FRAME** |  | 2009-02-02 | 2013-08-30 |  |  |  |  |  |  |  |  |  |  |  |  |  |  |  |  |  |  |  |  |  |  |  |  |  |  |  |  |  |  |  |  |  |  |  |  |  |  |  |  |  |  |  |  |
| 131121010 |  | Proc Space Frames | 148d | 2009-02-02 A | 2009-08-31 A | 1211020M5 FS-168d, 9-090M FS+79d | 100% |  |  | MECH DES [32 h]; MECH ENG [16 h] | 2,423.84 | 2,423.84 | 0 | 2423.84 | HOGAN J | 1 | 1 | H | JOHN H | 08-050 |  |  |  |  |  |  |  |  |  |  |  |  |  |  |  |  |  |  |  |  | 08-052 |  |  |  |  |  |  |  |  |
| 131121010ALOE |  | Vendor Fab Space Frames Labor FY09 | 24d | 2009-08-27 A | 2009-09-30 A | 9-090M FS+224d | 100% |  |  | MECH DES [5 h]; MECH ENG [7.5 h]; SR STAFF [2.5 h]; SUPPLIES & MATERIALS; TRAVEL | 2,602.68 | 954.88 | 0 | 2602.675 | HOGAN J | 1 | 1 | E | JOHN H |  | 10-027 | 10-064 |  |  |  |  |  |  |  |  |  | 12-018F |  |  |  | 100 | 100 |  |  | 10-066 |  | 3112A | 09-048 | 12-028F |  |  |  |  |  |
| 131121011 |  | Vend Fab Space Frames 10% of Material Costs | 120d | 2009-08-27 A | 2010-02-25 A | 131121010 FS-45d | 100% |  |  | PROCUREMENT<$50K 60 NO ESCALATION | 18,642.9 |  | 0 | 18642.9 | HOGAN J | 1 | 1 | P | JOHN H | 08-050 | 10-027 | 10-064 | 11-003 | 11-051 | 0 | 18642.9 | 1864290 | 100 |  |  | 09-017 | 12-018F |  |  | 10-001A |  |  |  |  |  |  | 3112A | 09-048 |  |  |  |  |  |  |
| 131121015 |  | Vend Fab Space Frames 50% of Cost (Fab/Ship) 1st Article | 177d | 2009-08-27 A | 2010-05-17 A | 131121011 FS-99d, 131121010 FS-1d | 100% |  |  | PROCUREMENT<$50K 60 NO ESCALATION | 22,260 |  | 0 | 22260 | HOGAN J | 1 | 1 | P | JOHN H | 08-050 | 10-027 | 10-064 | 11-003 | 11-051 | 0 | 22260 | 2226000 | 100 |  |  | 09-017 | 12-018F |  |  | 10-001A |  |  |  |  |  |  | 3112A | 09-048 |  | APP |  |  |  |  |
| 131121016 |  | Vend Fab Space Frames 50% of Cost (Fab/Ship) Upon Receipt of 1st Article | 182d | 2009-08-27 A | 2010-05-24 A | 131121015 FS-139d | 100% |  |  | PROCUREMENT<$50K 60 NO ESCALATION; PROCUREMENT>$50K 69 NO ESCALATION | 22,260 |  | 0 | 22260 | HOGAN J | 1 | 1 | P | JOHN H | 08-050 | 10-027 | 10-064 | 11-003 | 11-051 | 0 | 22260 | 2226000 | 100 |  |  | 09-017 | 12-018F |  |  | 10-001A |  |  |  |  |  |  | 3112A | 09-048 |  | APP | 09-012 |  |  |  |
| 131121016A |  | Vend Fab Space Frames Production 90% of Material | 182d | 2009-08-27 A | 2010-05-24 A | 131121016 FS-163d | 100% |  |  | PROCUREMENT>$50K 69 NO ESCALATION | 167,786.1 |  | 0 | 167786.1 | HOGAN J | 1 | 1 | P | JOHN H |  | 10-027 | 10-064 | 11-003 | 11-051 | 0 | 167786.1 | 16778610 | 100 |  |  |  | 12-018F |  |  | 10-001A |  |  |  |  |  |  | 3112A | 09-048 | 12-028F | APP |  | 11-012 |  |  |
| 131121016B |  | Vend Fab Space Frames Deliver Space Frame #2 | 313d | 2009-08-27 A | 2010-11-30 A | 131121016A FS-141d | 100% |  |  | PROCUREMENT>$50K 69 NO ESCALATION | 16,070 |  | 0 | 16070 | HOGAN J | 1 | 1 | P | JOHN H |  | 10-027 | 10-064 | 11-003 | 11-051 | 0 | 16070 | 1607000 | 100 |  |  |  |  |  |  | 10-001A |  |  |  |  |  |  | 3112A | 09-048 |  | APP |  | 11-012 |  |  |
| 131121016C |  | Vend Fab Space Frames Deliver Space Frame #3 | 313d | 2009-08-27 A | 2010-11-30 A | 131121016B FS-205d | 100% |  |  | PROCUREMENT>$50K 69 NO ESCALATION | 16,070 |  | 0 | 16070 | HOGAN J | 1 | 1 | P | JOHN H |  | 10-027 | 10-064 | 11-003 | 11-051 | 0 | 16070 | 1607000 | 100 |  |  |  | 12-018F |  |  | 10-001A |  |  |  |  |  |  | 3112A | 09-048 | 12-028F | APP |  | 11-012 |  |  |
| 131121016D |  | Vend Fab Space Frames Deliver Space Frame #4 | 339d | 2009-08-27 A | 2011-01-13 A | 131121016C FS-226d | 100% |  |  | PROCUREMENT>$50K 69 NO ESCALATION | 16,070 |  | 0 | 16070 | HOGAN J | 1 | 1 | P | JOHN H |  | 10-027 | 10-064 |  | 11-051 | 0 | 16070 | 1607000 | 100 |  |  |  | 12-018F |  |  | 10-001A |  |  |  |  | 10-066 |  | 3112A | 09-048 | 12-028F | APP |  | 11-012 |  |  |
| 131121016F |  | Vend Fab Space Frames Deliver Space Frame #5 | 374d | 2009-08-27 A | 2011-03-07 A | 131121016D FS-248d | 100% |  |  | PROCUREMENT>$50K 69 NO ESCALATION | 16,070 |  | 0 | 16070 | HOGAN J | 1 | 1 | P | JOHN H |  | 10-027 | 10-064 |  | 11-051 | 0 | 16070 | 1607000 | 100 |  |  |  | 12-018F |  |  | 10-001A |  |  |  |  | 10-066 |  | 3112A | 09-048 | 12-028F | APP |  | 11-012 |  |  |
| 131121016G |  | Vend Fab Space Frames Deliver Space Frame #6 | 424d | 2009-08-27 A | 2011-05-16 A | 131121016F FS-269d | 100% |  |  | PROCUREMENT>$50K 69 NO ESCALATION | 16,070 |  | 0 | 16070 | HOGAN J | 1 | 1 | P | JOHN H |  | 10-027 | 10-064 |  | 11-051 | 0 | 16070 | 1607000 | 100 |  |  |  | 12-018F |  |  | 10-001A |  |  |  |  | 10-066 |  | 3112A | 09-048 |  | APP |  | 11-012 |  |  |
| 131121016H |  | Vend Fab Space Frames Deliver Space Frame #7 | 467d | 2009-08-27 A | 2011-07-18 A | 131121016G FS-290d | 100% |  |  | PROCUREMENT>$50K 69 NO ESCALATION | 16,070 |  | 0 | 16070 | HOGAN J | 1 | 1 | P | JOHN H |  | 10-027 | 10-064 |  |  | 0 | 16070 | 1607000 | 100 |  |  |  | 12-018F |  |  | 10-001A |  |  |  |  | 10-066 |  | 3112A | 09-048 | 12-028F | APP |  |  |  |  |
| 131121016J |  | Vend Fab Space Frames Deliver Space Frame #8 | 487d | 2009-08-27 A | 2011-08-15 A | 131121016H FS-310d | 100% |  |  | PROCUREMENT>$50K 69 NO ESCALATION | 16,070 |  | 0 | 16070 | HOGAN J | 1 | 1 | P | JOHN H |  | 10-027 | 10-064 |  |  | 0 | 16070 | 1607000 | 100 |  |  |  | 12-018F |  |  | 10-001A |  |  |  |  | 10-066 |  | 3112A | 09-048 | 12-028F | APP |  |  |  |  |
| 131121016K |  | Vend Fab Space Frames Deliver Space Frame #9 | 528d | 2009-08-27 A | 2011-10-12 A | 131121016J FS-347d | 100% |  |  | PROCUREMENT>$50K 69 NO ESCALATION | 16,070 |  | 0 | 16070 | HOGAN J | 1 | 1 | P | JOHN H |  | 10-027 | 10-064 |  |  | 0 | 16070 | 1607000 | 100 |  |  |  | 12-018F |  |  | 10-001A |  |  |  |  | 10-066 |  | 3112A | 09-048 | 12-028F | APP |  |  |  |  |
| 131121016L |  | Vend Fab Space Frames Deliver Space Frame #10 | 551d | 2009-08-27 A | 2011-11-14 A | 131121016K FS-347d | 100% |  |  | PROCUREMENT>$50K 69 NO ESCALATION | 16,070 |  | 0 | 16070 | HOGAN J | 1 | 1 | P | JOHN H |  | 10-027 | 10-064 |  |  | 0 | 16070 | 1607000 | 100 |  |  |  | 12-018F |  |  | 10-001A |  |  |  |  | 10-066 |  | 3112A | 09-048 | 12-028F | APP |  |  |  |  |
| 131121010BLOE |  | Vendor Fab Space Frames Labor FY10 | 248d | 2009-10-01 A | 2010-09-30 A | 9-090M FS+224d, 131121010ALOE | 100% |  |  | TRAVEL; MECH DES [53 h]; MECH ENG [79.6 h]; SR STAFF [26.5 h]; SUPPLIES & MATERIALS | 28,680.4 | 10,451.56 | 0 | 28680.402291 | HOGAN J | 1 | 1 | E | JOHN H |  | 10-027 | 10-064 |  |  |  |  |  |  |  |  |  | 12-018F |  |  |  | 100 | 100 |  |  | 10-066 |  | 3112A | 09-048 | 12-028F |  |  |  |  |  |
| 131121020 |  | Receive & Insp Space Frame First Article (Lab Labor) | 21d | 2010-05-17 A | 2010-06-15 A | 131121016, 131121011, 131121010, 131121015 | 100% |  |  | SUPPLIES & MATERIALS; MECH DES [15.6 h]; MECH ENG [22.8 h]; MECH TECH [24 h] | 3,868.15 | 3,208.88 | 0 | 3868.154591 | HOGAN J | 1 | 1 | H | JOHN H | 08-050 | 10-027 | 10-064 | 11-003 | 11-051 |  |  |  |  |  |  | 09-017 | 12-018F |  |  |  |  |  |  |  |  |  |  | 09-048 |  |  |  |  |  |  |
| 131121040LOE |  | SOTR Oversight FY10 | 64d | 2010-07-01 A | 2010-09-30 A | 9-100M FS+184d | 100% |  |  | MECH ENG [60 h] | 3,951 | 3,951 | 0 | 3951 | HOGAN J | 1 | 1 | E | JOHN H |  |  | 10-064 |  |  |  |  |  |  |  |  |  | 12-018F |  |  |  | 100 | 100 |  |  | 10-066 |  |  |  | 12-028F |  |  |  |  |  |
| 131121010CLOE |  | Vendor Fab Space Frames Labor FY11 | 141d | 2010-10-01 A | 2011-04-29 A | 9-090M FS+224d, 131121010BLOE | 100% |  |  | MECH DES [22 h]; MECH ENG [32.9 h]; SR STAFF [11 h]; SUPPLIES & MATERIALS; TRAVEL | 12,248.07 | 4,467.12 | 0 | 12248.075 | HOGAN J | 1 | 1 | E | JOHN H |  | 10-027 | 10-064 |  |  |  |  |  |  |  |  |  | 12-018F |  |  |  | 100 | 100 |  |  | 10-066 |  | 3112A | 09-048 | 12-028F |  |  |  | 148936.1702 | -148836.1702 |
| 131121045LOE |  | SOTR Oversight FY11 | 138d | 2010-10-01 A | 2011-04-26 A | 131121040LOE | 100% |  |  | MECH ENG [120 h] | 8,154 | 8,154 | 0 | 8154 | HOGAN J | 1 | 1 | E | JOHN H |  |  | 10-064 |  |  |  |  |  |  |  |  |  | 12-018F |  |  |  | 100 | 100 |  |  | 10-066 |  |  |  | 12-028F |  |  |  | 130434.7826 | -130334.7826 |
| 131121021 |  | Receive & Insp Space Frame #2 | 17d | 2010-12-06 A | 2011-01-05 A | 131121010, 131121016B, 131121020, 131121016 | 100% |  |  | MECH ENG [18.24 h]; MECH TECH [19.2 h]; SUPPLIES & MATERIALS; MECH DES [12.48 h] | 3,308.19 | 2,648.92 | 0 | 3226.377791 | HOGAN J | 1 | 1 | H | JOHN H |  | 10-027 | 10-064 | 11-003 | 11-051 |  |  |  |  |  |  |  |  |  |  |  |  |  |  |  |  |  |  | 09-048 |  |  |  | 11-012 |  |  |
| 131121022 |  | Receive & Insp Space Frame #3 | 18d | 2010-12-06 A | 2011-01-06 A | 131121010, 131121016C, 131121016A, 131121021 | 100% |  |  | MECH ENG [15.2 h]; MECH TECH [16 h]; SUPPLIES & MATERIALS; MECH DES [10.4 h] | 2,866.7 | 2,207.43 | 0 | 2798.526591 | HOGAN J | 1 | 1 | H | JOHN H |  | 10-027 | 10-064 | 11-003 | 11-051 |  |  |  |  |  |  |  | 12-018F |  |  |  |  |  |  |  |  |  |  | 09-048 | 12-028F |  |  | 11-012 |  |  |
| 131121025 |  | Receive & Insp Space Frame #4 | 34d | 2011-01-10 A | 2011-02-28 A | 131121022, 131121016D | 100% |  |  | MECH TECH [14.4 h]; SUPPLIES & MATERIALS; MECH ENG [13.68 h]; MECH DES [9.36 h] | 2,645.96 | 1,986.69 | 0 | 2584.600991 | HOGAN J | 1 | 1 | H | JOHN H | 08-050 | 10-027 | 10-064 |  | 11-051 |  |  |  |  |  |  | 09-017 | 12-018F |  |  |  |  |  |  |  | 10-066 |  |  | 09-048 | 12-028F |  |  | 11-012 |  |  |
| 131121026 |  | Receive & Insp Space Frame #5 | 24d | 2011-03-25 A | 2011-04-27 A | 131121016F, 131121025 | 100% |  |  | MECH DES [9.36 h]; MECH ENG [13.68 h]; MECH TECH [14.4 h]; SUPPLIES & MATERIALS | 2,666.99 | 1,986.69 | 0 | 2666.9888 | HOGAN J | 1 | 1 | H | JOHN H |  | 10-027 | 10-064 |  | 11-051 |  |  |  |  |  |  |  | 12-018F |  |  |  |  |  |  |  | 10-066 |  |  | 09-048 | 12-028F |  |  | 11-012 |  |  |
| 131121027 |  | Receive & Insp Space Frame #6 | 11d | 2011-05-16 A | 2011-05-31 A | 131121026, 131121016G | 100% |  |  | SUPPLIES & MATERIALS; MECH ENG [13.68 h]; MECH TECH [14.4 h]; MECH DES [9.36 h] | 2,666.99 | 1,986.69 | 0 | 2666.9888 | HOGAN J | 1 | 1 | H | JOHN H |  | 10-027 | 10-064 |  | 11-051 |  |  |  |  |  |  |  | 12-018F |  |  |  |  |  |  |  | 10-066 |  |  | 09-048 |  |  |  | 11-012 |  |  |
| 131121028 |  | Receive & Insp Space Frame #7 | 5d | 2011-07-19 A | 2011-07-25 A | 131121016H, 131121027 | 100% |  |  | MECH ENG [13.68 h]; MECH TECH [14.4 h]; MECH DES [9.36 h]; SUPPLIES & MATERIALS | 2,666.99 | 1,986.69 | 0 | 2666.9888 | HOGAN J | 1 | 1 | H | JOHN H |  | 10-027 | 10-064 |  |  |  |  |  |  |  |  |  | 12-018F |  |  |  |  |  |  |  | 10-066 |  |  | 09-048 | 12-028F |  |  |  |  |  |
| 131121029 |  | Receive & Insp Space Frame #8 | 44d | 2011-08-16 A | 2011-10-17 A | 131121016J, 131121028 | 100% |  |  | MECH ENG [13.68 h]; MECH TECH [14.4 h]; MECH DES [9.36 h]; SUPPLIES & MATERIALS | 2,682.83 | 2,002.53 | 0 | 2666.9888 | HOGAN J | 1 | 1 | H | JOHN H |  | 10-027 | 10-064 |  |  |  |  |  |  |  |  |  | 12-018F |  |  |  |  |  |  |  | 10-066 |  |  | 09-048 | 12-028F |  |  |  |  |  |
| 131121030 |  | Receive & Insp Space Frame #9 | 5d | 2011-10-18 A | 2011-10-24 A | 131121016K, 131121029 | 100% |  |  | MECH ENG [13.68 h]; SUPPLIES & MATERIALS; MECH DES [9.36 h]; MECH TECH [14.4 h] | 2,730.35 | 2,050.05 | 0 | 2666.9888 | HOGAN J | 1 | 1 | H | JOHN H | 08-050 | 10-027 | 10-064 |  |  |  |  |  |  |  |  | 09-017 | 12-018F |  |  |  |  |  |  |  | 10-066 |  |  | 09-048 | 12-028F |  |  |  |  |  |
| 131121035 |  | Receive & Insp Space Frame #10 | 24d | 2011-11-14 A | 2011-12-19 A | 131121016L, 131121030 | 100% |  |  | MECH DES [9.36 h]; MECH ENG [13.68 h]; SUPPLIES & MATERIALS; MECH TECH [14.4 h] | 2,730.35 | 2,050.05 | 0 | 2666.9888 | HOGAN J | 1 | 1 | H | JOHN H |  | 10-027 | 10-064 |  |  |  |  |  |  |  |  |  | 12-018F |  |  |  |  |  |  |  | 10-066 |  |  | 09-048 | 12-028F |  |  |  |  |  |
| 131121050 |  | Re-Baseline Actuals Adjustment | 1d | 2013-08-30 A | 2013-08-30 A |  | 100% | 2013-09-03 | 2013-09-03 | PROCUREMENT>$50K 69 NO ESCALATION | 70,849.01 |  |  | 70849.01 |  |  |  |  |  |  |  |  |  |  | 0 | 70849.01 | 7084901 | 100 |  |  |  |  | ADJ |  |  |  |  |  |  |  |  |  |  |  |  |  |  |  |  |

Notes:
- 131121010: Explanation: Removing Negative lag from successor.

| ID | WBS | Activity | Duration | Start | Finish | Predecessors | Complete | Planned start | Planned finish | Resources | Cost | Actual cost | Calculated Remaining Total Cost | MONTHLY EV COST | RESP - Responsibility | STRT%COMP for CM EVM | FNSH%COMP for CM EVM | EVMS Reporting Codes | CAM RESPONSIBLE | CR 08-050 | CR 09-051 | CR 10-027 | CR 10-064 | CR 11-003 | CR 11-051 | CR 12-018 | CR 07-024 | CR 07-027 | Profile change | Advance Purchase Plan > 500K | CR 08-016 | 12 GEV MAJOR PROCUREMENT CATAGORY | CR 09-012 | CR 11-012 | Remaining Material Cost Based on % Compl | Claimed Material Cost Based on % Complet | Initial Claimed Material Calc | Claimed Material Divider | CR 12-028 | CR 10-066 | LOE Divider | LOE Multiplier | CR 08-052 | CR 09-017 | CR 10-012 | ReBaseline Actuals Adjustment |
| --- | --- | --- | --- | --- | --- | --- | --- | --- | --- | --- | --- | --- | --- | --- | --- | --- | --- | --- | --- | --- | --- | --- | --- | --- | --- | --- | --- | --- | --- | --- | --- | --- | --- | --- | --- | --- | --- | --- | --- | --- | --- | --- | --- | --- | --- | --- |
|  | 2 | **1.3.1.1.2.2 TUNERS** |  | 2009-02-09 | 2013-08-30 |  |  |  |  |  |  |  |  |  |  |  |  |  |  |  |  |  |  |  |  |  |  |  |  |  |  |  |  |  |  |  |  |  |  |  |  |  |  |  |  |  |
| 131122010 |  | Proc Tuners | 144d | 2009-02-09 A | 2009-09-01 A | 9-090M | 100% |  |  | MECH ENG [16 h]; MECH DES [32 h] | 2,423.84 | 2,423.84 | 0 | 2423.84 | HOGAN J | 1 | 1 | H | JOHN H | 08-050 | 09-051 | 10-027 | 10-064 | 11-003 | 11-051 | 12-018F |  |  |  |  |  |  |  |  |  |  |  |  |  |  |  |  |  |  |  |  |
| 131122015 |  | Vend Fab - Cold Tuners Lot #1 (Phase 1) FY09 Original Labor | 15d | 2009-09-09 A | 2009-09-29 A | 131122010 FS-66d | 100% |  |  | SR STAFF [3.36 h]; SUPPLIES & MATERIALS; TRAVEL; MECH DES [3.36 h]; MECH ENG [6.72 h] | 2,263.31 | 921.64 | 0 | 2263.318 | HOGAN J | 1 | 1 | P | JOHN H | 08-050 | 09-051 | 10-027 | 10-064 | 11-003 | 11-051 |  | 07-024 | 07-027 | C | APP | 08-016 | 3112B | 09-012 | 11-012 |  |  |  |  |  |  |  |  |  |  |  |  |
| 131122016A |  | Vend Fab - Cold Tuners - Materials | 57d | 2009-09-09 A | 2009-11-30 A | 131122010 FS-61d | 100% |  |  | PROCUREMENT<$50K 60 NO ESCALATION; PROCUREMENT>$50K 69 NO ESCALATION | 140,707.2 |  | 0 | 140707.2 | HOGAN J | 1 | 1 | P | JOHN H |  | 09-051 | 10-027 | 10-064 | 11-003 | 11-051 | 12-018F |  |  | C | APP |  | 3112B |  |  | 0 | 140707.2 | 14070720 | 100 |  |  |  |  |  |  |  |  |
| 131122016B |  | Vend Fab - Cold Tuners - First Article | 107d | 2009-09-09 A | 2010-02-18 A | 131122016A FS-16d | 100% |  |  | PROCUREMENT>$50K 69 NO ESCALATION | 11,556.6 |  | 0 | 11556.6 | HOGAN J | 1 | 1 | P | JOHN H |  | 09-051 | 10-027 | 10-064 | 11-003 | 11-051 | 12-018F |  |  | C | APP |  | 3112B |  |  | 0 | 11556.6 | 1155660 | 100 |  |  |  |  |  |  |  |  |
| 131122016C |  | Vend Fab - Cold Tuners - 2 thru 10 | 129d | 2009-09-09 A | 2010-03-22 A | 131122016B FS-38d | 100% |  |  | PROCUREMENT>$50K 69 NO ESCALATION | 17,865.09 |  | 0 | 17865.09 | HOGAN J | 1 | 1 | P | JOHN H |  | 09-051 | 10-027 | 10-064 | 11-003 | 11-051 | 12-018F |  |  | C | APP |  | 3112B |  |  | 0 | 17865.09 | 1786509 | 100 |  |  |  |  |  |  |  |  |
| 131122016D |  | Vend Fab - Cold Tuners - 11 thru 20 | 134d | 2009-09-09 A | 2010-03-29 A | 131122016C FS-94d | 100% |  |  | PROCUREMENT>$50K 69 NO ESCALATION | 19,850.1 |  | 0 | 19850.1 | HOGAN J | 1 | 1 | P | JOHN H |  | 09-051 | 10-027 | 10-064 | 11-003 | 11-051 |  |  |  | C | APP |  | 3112B |  | 11-012 | 0 | 19850.1 | 1985010 | 100 |  |  |  |  |  |  |  |  |
| 131122016F |  | Vend Fab - Cold Tuners - 21 thru 30 | 232d | 2009-09-09 A | 2010-08-16 A | 131122016D FS-113d | 100% |  |  | PROCUREMENT>$50K 69 NO ESCALATION | 19,850.1 |  | 0 | 19850.1 | HOGAN J | 1 | 1 | P | JOHN H |  | 09-051 | 10-027 | 10-064 | 11-003 | 11-051 | 12-018F |  |  | C | APP |  | 3112B |  | 11-012 | 0 | 19850.1 | 1985010 | 100 | 12-028F |  |  |  |  |  |  |  |
| 131122016G |  | Vend Fab - Cold Tuners - 31 thru 40 | 237d | 2009-09-09 A | 2010-08-23 A | 131122016F FS-136d | 100% |  |  | PROCUREMENT>$50K 69 NO ESCALATION | 19,850.1 |  | 0 | 19850.1 | HOGAN J | 1 | 1 | P | JOHN H |  | 09-051 | 10-027 | 10-064 |  | 11-051 | 12-018F |  |  | C | APP |  | 3112B |  | 11-012 | 0 | 19850.1 | 1985010 | 100 | 12-028F | 10-066 |  |  |  |  |  |  |
| 131122016H |  | Vend Fab - Cold Tuners - 41 thru 50 | 256d | 2009-09-09 A | 2010-09-20 A | 131122016G FS-158d | 100% |  |  | PROCUREMENT>$50K 69 NO ESCALATION | 19,850.1 |  | 0 | 19850.1 | HOGAN J | 1 | 1 | P | JOHN H |  | 09-051 | 10-027 | 10-064 |  | 11-051 | 12-018F |  |  | C | APP |  | 3112B |  | 11-012 | 0 | 19850.1 | 1985010 | 100 | 12-028F | 10-066 |  |  |  |  |  |  |
| 131122016J |  | Vend Fab - Cold Tuners - 51 thru 60 | 252d | 2009-09-09 A | 2010-09-14 A | 131122016H FS-178d | 100% |  |  | PROCUREMENT>$50K 69 NO ESCALATION | 19,850.1 |  | 0 | 19850.1 | HOGAN J | 1 | 1 | P | JOHN H |  | 09-051 | 10-027 | 10-064 |  | 11-051 | 12-018F |  |  | C | APP |  | 3112B |  | 11-012 | 0 | 19850.1 | 1985010 | 100 |  | 10-066 |  |  |  |  |  |  |
| 131122016K |  | Vend Fab - Cold Tuners - 61 thru 70 | 281d | 2009-09-09 A | 2010-10-25 A | 131122016J FS-200d | 100% |  |  | PROCUREMENT>$50K 69 NO ESCALATION | 19,850.1 |  | 0 | 19850.1 | HOGAN J | 1 | 1 | P | JOHN H |  | 09-051 | 10-027 | 10-064 |  |  | 12-018F |  |  | C | APP |  | 3112B |  |  | 0 | 19850.1 | 1985010 | 100 | 12-028F | 10-066 |  |  |  |  |  |  |
| 131122016L |  | Vend Fab - Cold Tuners - 71 thru 80 | 281d | 2009-09-09 A | 2010-10-25 A | 131122016K FS-221d | 100% |  |  | PROCUREMENT>$50K 69 NO ESCALATION | 19,850.1 |  | 0 | 19850.1 | HOGAN J | 1 | 1 | P | JOHN H |  | 09-051 | 10-027 | 10-064 |  |  | 12-018F |  |  | C | APP |  | 3112B |  |  | 0 | 19850.1 | 1985010 | 100 | 12-028F | 10-066 |  |  |  |  |  |  |
| 131122016N |  | Vend Fab - Cold Tuners - 81 thru 84 | 281d | 2009-09-09 A | 2010-10-25 A | 131122016L FS-243d | 100% |  |  | PROCUREMENT>$50K 69 NO ESCALATION | 7,940.04 |  | 0 | 7940.04 | HOGAN J | 1 | 1 | P | JOHN H |  | 09-051 | 10-027 | 10-064 |  |  | 12-018F |  |  | C | APP |  | 3112B |  |  | 0 | 7940.04 | 794004 | 100 | 12-028F | 10-066 |  |  |  |  |  |  |
| 131122015A |  | Vend Fab - Cold Tuners Lot #1 (Phase 1) FY10 Original Labor | 19d | 2009-11-02 A | 2009-11-30 A | 131122015 | 100% |  |  | MECH ENG [25.28 h]; SR STAFF [12.64 h]; SUPPLIES & MATERIALS; MECH DES [12.64 h]; TRAVEL | 8,786.13 | 3,577.88 | 0 | 8786.125356 | HOGAN J | 1 | 1 | P | JOHN H |  | 09-051 | 10-027 | 10-064 | 11-003 | 11-051 |  |  |  | C | APP |  | 3112B |  | 11-012 |  |  |  |  |  |  |  |  |  |  |  |  |
| 131122016 |  | Vend Fab - Cold Tuners Lot #2 & 3 (Phase 2) Original Labor | 121d | 2010-02-01 A | 2010-07-22 A | 131122015, 131122015A FS+38d | 100% |  |  | SR STAFF [24 h]; SUPPLIES & MATERIALS; TRAVEL; MECH DES [24 h]; MECH ENG [48 h] | 16,682.51 | 6,793.44 | 0 | 16682.509184 | HOGAN J | 1 | 1 | E | JOHN H | 08-050 | 09-051 | 10-027 | 10-064 | 11-003 | 11-051 | 12-018F | 07-024 | 07-027 | C | APP | 08-016 | 3112B | 09-012 | 11-012 |  |  |  |  | 12-028F | 10-066 | 100 | 100 |  |  |  |  |
| 131122017 |  | Receive & Insp First Article Tuner | 35d | 2010-02-08 A | 2010-03-29 A | 131122016B, 131122015 FS-64d, 131122015A FS-64d | 100% |  |  | MECH DES [8 h]; MECH ENG [8 h]; MECH TECH [8 h]; SUPPLIES & MATERIALS | 1,332.52 | 1,222.64 | 0 | 1332.516712 | HOGAN J | 1 | 1 | H | JOHN H | 08-050 | 09-051 | 10-027 | 10-064 | 11-003 | 11-051 | 12-018F |  |  |  |  |  |  |  |  |  |  |  |  |  |  |  |  |  |  |  |  |
| 131122020 |  | Receive & Insp Tuners Lot #1 2-10 | 6d | 2010-03-22 A | 2010-03-29 A | 131122015 FS-64d, 131122016C, 131122015A FS-64d | 100% |  |  | SUPPLIES & MATERIALS; MECH DES [32 h]; MECH ENG [32 h]; MECH TECH [32 h] | 5,330.08 | 4,890.56 | 0 | 5330.077167 | HOGAN J | 1 | 1 | H | JOHN H | 08-050 | 09-051 | 10-027 | 10-064 | 11-003 | 11-051 | 12-018F |  |  |  |  |  |  |  |  |  |  |  |  |  |  |  |  |  |  |  |  |
| 131122025 |  | Receive & Insp Tuners Lot #2 11-20 | 23d | 2010-03-29 A | 2010-04-28 A | 131122017 FS-1d, 131122015A FS-20d, 131122020 FS-1d, 131122015 FS-20d, 131122016D | 100% |  |  | MECH DES [8 h]; SUPPLIES & MATERIALS; MECH ENG [40 h]; MECH TECH [40 h] | 5,214.91 | 4,665.52 | 0 | 5214.913879 | HOGAN J | 1 | 1 | H | JOHN H | 08-050 | 09-051 | 10-027 | 10-064 | 11-003 | 11-051 |  |  |  |  |  |  |  |  | 11-012 |  |  |  |  |  |  |  |  |  |  |  |  |
| 131122065 |  | Vend Fab - Warm Tuners Lot # 1(FROZEN) | 68d | 2010-04-26 A | 2010-07-30 A | 9-100M | 100% |  |  | PROCUREMENT<$50K 60; PROCUREMENT>$50K 69 | 140,222.77 |  | 0 | 140222.77 | HOGAN J | 1 | 1 | P | JOHN H | 08-050 |  | 10-027 | 10-064 | 11-003 | 11-051 | 12-018F | 07-024 | 07-027 | C | APP |  | 3112C |  |  | 0 | 140222.77 | 14022277 | 100 |  |  |  |  | 08-052 | 09-017 | 10-012 |  |
| 131122065B |  | Vend Fab - Warm Tuners Peg Point #1 Receipt of Materials | 63d | 2010-05-03 A | 2010-07-30 A | 9-100M FS+162d | 100% |  |  | PROCUREMENT<$50K 60 NO ESCALATION; PROCUREMENT>$50K 69 NO ESCALATION | 100,000 |  | 0 | 100000 | HOGAN J | 1 | 1 | P | JOHN H | 08-050 |  | 10-027 | 10-064 | 11-003 | 11-051 | 12-018F | 07-024 | 07-027 | C | APP |  | 3112C |  |  | 0 | 100000 | 10000000 | 100 |  |  |  |  | 08-052 | 09-017 | 10-012 |  |
| 131122065C |  | Vend Fab - Warm Tuners Peg Point #2 Receipt of Balance of Materials | 69d | 2010-05-03 A | 2010-08-09 A | 131122065B FS-47d | 100% |  |  | PROCUREMENT>$50K 69 | 100,172.5 |  | 0 | 100172.5 | HOGAN J | 1 | 1 | D | JOHN H |  |  |  | 10-064 | 11-003 | 11-051 | 12-018F |  |  | C | APP |  | 3112C |  |  | 0 | 100172.5 | 10017250 | 100 |  |  |  |  |  |  |  |  |
| 131122065D |  | Vend Fab - Warm Tuners Peg Point #3 Receipt of R100 Materials | 74d | 2010-05-03 A | 2010-08-16 A | 131122065C FS-69d | 100% |  |  |  |  |  |  | 0 | HOGAN J | 1 | 1 | D | JOHN H |  |  |  | 10-064 | 11-003 | 11-051 | 12-018F |  |  | C | APP |  | 3112C |  |  |  |  |  |  |  |  |  |  |  |  |  |  |
| 131122065F |  | Vend Fab - Warm Tuners Peg Point #4 Receipt of First Article | 106d | 2010-05-03 A | 2010-09-30 A | 131122065D FS-69d | 100% |  |  | PROCUREMENT>$50K 69 | 4,446.51 |  | 0 | 4446.51 | HOGAN J | 1 | 1 | D | JOHN H |  |  |  | 10-064 | 11-003 | 11-051 | 12-018F |  |  | C | APP |  | 3112C |  |  | 0 | 4446.51 | 444651 | 100 |  |  |  |  |  |  |  |  |
| 131122065G |  | Vend Fab - Warm Tuners Peg Point #5 Receipt of 1st Production Set | 161d | 2010-05-03 A | 2010-12-20 A | 131122065F FS-90d | 100% |  |  | PROCUREMENT>$50K 69 NO ESCALATION | 20,815 |  | 0 | 20815 | HOGAN J | 1 | 1 | D | JOHN H |  |  |  | 10-064 | 11-003 | 11-051 | 12-018F |  |  | C | APP |  | 3112C |  |  | 0 | 20815 | 2081500 | 100 |  |  |  |  |  |  |  |  |
| 131122065H |  | Vend Fab - Warm Tuners Peg Point #6 Receipt of 2nd Production Set | 168d | 2010-05-03 A | 2011-01-06 A | 131122065G FS-111d | 100% |  |  | PROCUREMENT>$50K 69 NO ESCALATION | 20,815.1 |  | 0 | 20815.1 | HOGAN J | 1 | 1 | D | JOHN H |  |  |  | 10-064 | 11-003 | 11-051 |  |  |  | C | APP |  | 3112C |  | 11-012 | 0 | 20815.1 | 2081510 | 100 |  |  |  |  |  |  |  |  |
| 131122065J |  | Vend Fab - Warm Tuners Peg Point #7 Receipt of 3rd Production Set | 178d | 2010-05-03 A | 2011-01-21 A | 131122065H FS-131d | 100% |  |  | PROCUREMENT>$50K 69 NO ESCALATION | 20,815.1 |  | 0 | 20815.1 | HOGAN J | 1 | 1 | D | JOHN H |  |  |  | 10-064 | 11-003 | 11-051 | 12-018F |  |  | C | APP |  | 3112C |  | 11-012 | 0 | 20815.1 | 2081510 | 100 | 12-028F |  |  |  |  |  |  |  |
| 131122065K |  | Vend Fab - Warm Tuners Peg Point #8 Receipt of 4th Production Set | 203d | 2010-05-03 A | 2011-02-28 A | 131122065J FS-148d | 100% |  |  | PROCUREMENT>$50K 69 NO ESCALATION | 20,815.1 |  | 0 | 20815.1 | HOGAN J | 1 | 1 | D | JOHN H |  |  |  | 10-064 |  | 11-051 | 12-018F |  |  | C | APP |  | 3112C |  | 11-012 | 0 | 20815.1 | 2081510 | 100 | 12-028F | 10-066 |  |  |  |  |  |  |
| 131122065L |  | Vend Fab - Warm Tuners Peg Point #9 Receipt of 5th Production Set | 203d | 2010-05-03 A | 2011-02-28 A | 131122065K FS-187d | 100% |  |  | PROCUREMENT>$50K 69 NO ESCALATION | 20,815.1 |  | 0 | 20815.1 | HOGAN J | 1 | 1 | D | JOHN H |  |  |  | 10-064 |  | 11-051 | 12-018F |  |  | C | APP |  | 3112C |  |  | 0 | 20815.1 | 2081510 | 100 | 12-028F | 10-066 |  |  |  |  |  |  |
| 131122065N |  | Vend Fab - Warm Tuners Peg Point #10 Receipt of 6th Production Set | 243d | 2010-05-03 A | 2011-04-25 A | 131122065L FS-210d | 100% |  |  | PROCUREMENT>$50K 69 NO ESCALATION | 20,815.1 |  | 0 | 20815.1 | HOGAN J | 1 | 1 | D | JOHN H |  |  |  | 10-064 |  | 11-051 | 12-018F |  |  | C | APP |  | 3112C |  |  | 0 | 20815.1 | 2081510 | 100 |  | 10-066 |  |  |  |  |  |  |
| 131122065P |  | Vend Fab - Warm Tuners Peg Point #11 Receipt of 7th Production Set | 243d | 2010-05-03 A | 2011-04-25 A | 131122065N FS-231d | 100% |  |  | PROCUREMENT>$50K 69 NO ESCALATION | 20,815.1 |  | 0 | 20815.1 | HOGAN J | 1 | 1 | D | JOHN H |  |  |  | 10-064 |  | 11-051 | 12-018F |  |  | C | APP |  | 3112C |  |  | 0 | 20815.1 | 2081510 | 100 | 12-028F | 10-066 |  |  |  |  |  |  |
| 131122065Q |  | Vend Fab - Warm Tuners Peg Point #12 Receipt of 8th Production Set | 257d | 2010-05-03 A | 2011-05-15 A | 131122065P FS-274d | 100% | 2010-05-03 | 2011-05-13 | PROCUREMENT>$50K 69 NO ESCALATION | 20,815.1 |  | 0 | 20815.1 | HOGAN J | 1 | 1 | D | JOHN H |  |  |  | 10-064 |  | 11-051 | 12-018F |  |  | C | APP |  | 3112C |  |  | 0 | 20815.1 | 2081510 | 100 | 12-028F | 10-066 |  |  |  |  |  |  |
| 131122065R |  | Vend Fab - Warm Tuners Peg Point #13 Receipt of R100 Production Set | 243d | 2010-05-03 A | 2011-04-25 A | 131122065Q FS-294d | 100% |  |  |  |  |  |  | 0 | HOGAN J | 1 | 1 | D | JOHN H |  |  |  | 10-064 |  | 11-051 | 12-018F |  |  | C | APP |  | 3112C |  |  |  |  |  |  | 12-028F | 10-066 |  |  |  |  |  |  |
| 131122065A |  | Vend Fab - Warm Tuners Lot # 1 Reverse Entry Per CR 10-064 | 4d | 2010-07-26 A | 2010-07-29 A | 9-100M FS+120d | 100% |  |  | PROCUREMENT<$50K 60; PROCUREMENT>$50K 69 | -140,222.77 |  |  |  | HOGAN J | 1 | 1 | P | JOHN H | 08-050 |  | 10-027 | 10-064 | 11-003 | 11-051 |  | 07-024 | 07-027 | C | APP |  | 3112C |  | 11-012 |  |  |  | 100 |  |  |  |  | 08-052 | 09-017 | 10-012 |  |
| 131122030 |  | Receive & Insp Tuners Lot #3 21-30 | 6d | 2010-08-16 A | 2010-08-23 A | 131122016F, 131122015A, 131122015, 131122025 | 100% |  |  | MECH TECH [40 h]; MECH DES [8 h]; MECH ENG [12 h]; SUPPLIES & MATERIALS | 3,371.11 | 2,821.72 | 0 | 3371.113879 | HOGAN J | 1 | 1 | H | JOHN H | 08-050 | 09-051 | 10-027 | 10-064 | 11-003 | 11-051 | 12-018F |  |  |  |  |  |  |  | 11-012 |  |  |  |  | 12-028F |  |  |  |  |  |  |  |
| 131122035 |  | Receive & Insp Tuners Lot #4 31-40 | 6d | 2010-08-23 A | 2010-08-30 A | 131122016G, 131122016 FS-100d, 131122030 | 100% |  |  | SUPPLIES & MATERIALS; MECH TECH [40 h]; MECH DES [8 h]; MECH ENG [12 h] | 3,371.11 | 2,821.72 | 0 | 3371.113879 | HOGAN J | 1 | 1 | H | JOHN H | 08-050 | 09-051 | 10-027 | 10-064 |  | 11-051 | 12-018F |  |  |  |  |  |  |  | 11-012 |  |  |  |  | 12-028F | 10-066 |  |  |  |  |  |  |
| 131122070 |  | Recieve & Inspect Warm Tuners - First Article | 10d | 2010-09-10 A | 2010-09-23 A | 131122065F FS-26d, 131122065 FS+4d | 100% |  |  | MECH TECH [80 h]; MECH ENG [40 h] | 5,973.2 | 5,973.2 | 0 | 6163.6 | HOGAN J | 1 | 1 | P | JOHN H | 08-050 |  | 10-027 | 10-064 | 11-003 | 11-051 | 12-018F | 07-024 | 07-027 | C | APP |  |  |  |  |  |  |  |  |  |  |  |  | 08-052 | 09-017 | 10-012 |  |
| 131122040 |  | Receive & Insp Tuners Lot #5 41-50 | 26d | 2010-09-20 A | 2010-10-25 A | 131122016 FS-80d, 131122016H, 131122035 | 100% |  |  | MECH DES [8 h]; SUPPLIES & MATERIALS; MECH ENG [12 h]; MECH TECH [40 h] | 3,429.9 | 2,880.51 | 0 | 3371.113879 | HOGAN J | 1 | 1 | H | JOHN H | 08-050 | 09-051 | 10-027 | 10-064 |  | 11-051 | 12-018F |  |  |  |  |  |  |  | 11-012 |  |  |  |  | 12-028F | 10-066 |  |  |  |  |  |  |
| 131122045 |  | Receive & Insp Tuners Lot #6 51-60 | 26d | 2010-09-20 A | 2010-10-25 A | 131122016J, 131122040, 131122016 FS-60d | 100% |  |  | SUPPLIES & MATERIALS; MECH DES [8 h]; MECH ENG [12 h]; MECH TECH [40 h] | 3,429.9 | 2,880.51 | 0 | 3371.113879 | HOGAN J | 1 | 1 | H | JOHN H | 08-050 | 09-051 | 10-027 | 10-064 |  | 11-051 | 12-018F |  |  |  |  |  |  |  | 11-012 |  |  |  |  |  | 10-066 |  |  |  |  |  |  |
| 131122050 |  | Receive & Insp Tuners Lot #7 61-70 | 10d | 2010-11-15 A | 2010-11-30 A | 131122045, 131122016K, 131122016 FS-40d | 100% |  |  | MECH DES [8 h]; SUPPLIES & MATERIALS; MECH TECH [40 h]; MECH ENG [12 h] | 3,461.03 | 2,911.64 | 0 | 3371.113879 | HOGAN J | 1 | 1 | H | JOHN H | 08-050 | 09-051 | 10-027 | 10-064 |  |  | 12-018F |  |  |  |  |  |  |  |  |  |  |  |  | 12-028F | 10-066 |  |  |  |  |  |  |
| 131122055 |  | Receive & Insp Tuners Lot #8 71-80 | 8d | 2010-12-03 A | 2010-12-14 A | 131122016L, 131122016 FS-20d, 131122050 | 100% |  |  | SUPPLIES & MATERIALS; MECH TECH [40 h]; MECH DES [8 h]; MECH ENG [12 h] | 3,461.03 | 2,911.64 | 0 | 3371.113879 | HOGAN J | 1 | 1 | H | JOHN H | 08-050 | 09-051 | 10-027 | 10-064 |  |  | 12-018F |  |  |  |  |  |  |  |  |  |  |  |  | 12-028F | 10-066 |  |  |  |  |  |  |
| 131122075 |  | Recieve & Inspect Warm Tuners - 1st Production Set | 17d | 2010-12-06 A | 2011-01-05 A | 131122070, 131122065G FS-26d | 100% |  |  | MECH ENG [24 h]; MECH TECH [40 h] | 3,353.6 | 3,353.6 | 0 | 3353.6 | HOGAN J | 1 | 1 | H | JOHN H | 08-050 |  | 10-027 | 10-064 | 11-003 | 11-051 | 12-018F | 07-024 | 07-027 | C | APP |  |  |  |  |  |  |  |  |  |  |  |  | 08-052 | 09-017 | 10-012 |  |
| 131122060 |  | Receive & Insp Tuners Lot #9 81-84 | 5d | 2010-12-15 A | 2010-12-23 A | 131122016N, 131122016, 131122055 | 100% | 2010-12-15 | 2010-12-21 | SUPPLIES & MATERIALS; MECH TECH [40 h]; MECH DES [8 h]; MECH ENG [12 h] | 3,478.56 | 2,911.64 | 0 | 3478.56 | HOGAN J | 1 | 1 | H | JOHN H | 08-050 | 09-051 | 10-027 | 10-064 |  |  | 12-018F | 07-024 | 07-027 |  |  |  |  |  |  |  |  |  |  | 12-028F | 10-066 |  |  |  | 09-017 |  |  |
| 131122080 |  | Recieve & Inspect Warm Tuners - 2nd Production Set | 16d | 2011-01-06 A | 2011-01-28 A | 131122065H FS-26d, 131122065A | 100% |  |  | MECH ENG [24 h]; MECH TECH [40 h] | 3,353.6 | 3,353.6 | 0 | 3353.6 | HOGAN J | 1 | 1 | H | JOHN H | 08-050 |  | 10-027 | 10-064 | 11-003 | 11-051 |  | 07-024 | 07-027 | C | APP |  |  |  | 11-012 |  |  |  |  |  |  |  |  | 08-052 | 09-017 | 10-012 |  |
| 131122085 |  | Recieve & Inspect Warm Tuners - 3rd Production Set | 20d | 2011-01-31 A | 2011-02-28 A | 131122080, 131122065J FS-26d | 100% |  |  | MECH ENG [24 h]; MECH TECH [40 h] | 3,353.6 | 3,353.6 | 0 | 3353.6 | HOGAN J | 1 | 1 | H | JOHN H | 08-050 |  | 10-027 | 10-064 | 11-003 | 11-051 | 12-018F | 07-024 | 07-027 | C | APP |  |  |  | 11-012 |  |  |  |  | 12-028F |  |  |  | 08-052 | 09-017 | 10-012 |  |
| 131122090 |  | Recieve & Inspect Warm Tuners - 4th Production Set | 19d | 2011-02-01 A | 2011-02-28 A | 131122065K FS-26d, 131122065B | 100% |  |  | MECH ENG [24 h]; MECH TECH [40 h] | 3,353.6 | 3,353.6 | 0 | 3353.6 | HOGAN J | 1 | 1 | H | JOHN H | 08-050 |  | 10-027 | 10-064 |  | 11-051 | 12-018F | 07-024 | 07-027 | C | APP |  |  |  | 11-012 |  |  |  |  | 12-028F | 10-066 |  |  | 08-052 | 09-017 | 10-012 |  |
| 131122095 |  | Recieve & Inspect Warm Tuners - 5th Production Set | 39d | 2011-02-01 A | 2011-03-28 A | 131122065L FS-26d, 131122090 | 100% |  |  | MECH TECH [40 h]; MECH ENG [24 h] | 3,353.6 | 3,353.6 | 0 | 3353.6 | HOGAN J | 1 | 1 | H | JOHN H | 08-050 |  | 10-027 | 10-064 |  | 11-051 | 12-018F | 07-024 | 07-027 | C | APP |  |  |  | 11-012 |  |  |  |  | 12-028F | 10-066 |  |  | 08-052 | 09-017 | 10-012 |  |
| 131122100 |  | Recieve & Inspect Warm Tuners - 6th Production Set | 16d | 2011-04-02 A | 2011-04-25 A | 131122065N | 100% | 2011-04-04 | 2011-04-25 | MECH ENG [24 h]; MECH TECH [40 h] | 3,353.6 | 3,353.6 | 0 | 3353.6 | HOGAN J | 1 | 1 | H | JOHN H |  |  |  | 10-064 |  | 11-051 | 12-018F |  |  | C | APP |  |  |  | 11-012 |  |  |  |  |  | 10-066 |  |  |  |  |  |  |
| 131122105 |  | Recieve & Inspect Warm Tuners - 7th Production Set | 28d | 2011-04-20 A | 2011-05-28 A | 131122065P | 100% | 2011-04-20 | 2011-05-27 | MECH ENG [24 h]; MECH TECH [40 h] | 3,353.6 | 3,353.6 | 0 | 3353.6 | HOGAN J | 1 | 1 | H | JOHN H |  |  |  | 10-064 |  | 11-051 | 12-018F |  |  | C | APP |  |  |  |  |  |  |  |  | 12-028F | 10-066 |  |  |  |  |  |  |
| 131122110 |  | Recieve & Inspect Warm Tuners - 8th Production Set | 10d | 2011-05-16 A | 2011-05-30 A | 131122065Q | 100% | 2011-05-16 | 2011-05-27 | MECH ENG [24 h]; MECH TECH [40 h] | 3,353.6 | 3,353.6 | 0 | 3353.6 | HOGAN J | 1 | 1 | H | JOHN H |  |  |  | 10-064 |  | 11-051 | 12-018F |  |  | C | APP |  |  |  |  |  |  |  |  | 12-028F | 10-066 |  |  |  |  |  |  |
| 131122115 |  | Re-Baseline Actuals Adjustment | 1d | 2013-08-30 A | 2013-08-30 A |  | 100% | 2013-09-03 | 2013-09-03 | PROCUREMENT>$50K 69 NO ESCALATION | 251,623.84 |  |  | 251623.84 |  |  |  |  |  |  |  |  |  |  |  |  |  |  |  |  |  |  |  |  | 0 | 251623.84 | 25162384 | 100 |  |  |  |  |  |  |  | ADJ |

| ID | WBS | Activity | Duration | Start | Finish | Predecessors | Complete | Planned start | Planned finish | Resources | Cost | Actual cost | Calculated Remaining Total Cost | MONTHLY EV COST | RESP - Responsibility | STRT%COMP for CM EVM | FNSH%COMP for CM EVM | EVMS Reporting Codes | CAM RESPONSIBLE | CR 08-050 | CR 10-027 | CR 10-064 | CR 11-003 | CR 11-051 | CR 12-018 | CR 12-028 | Remaining Material Cost Based on % Compl | Claimed Material Cost Based on % Complet | Initial Claimed Material Calc | Claimed Material Divider | Advance Purchase Plan > 500K | CR 08-052 | CR 09-017 | CR 10-001 | CR 10-066 | CR 11-012 | ReBaseline Actuals Adjustment | CR 09-012 | CR 11-001 |
| --- | --- | --- | --- | --- | --- | --- | --- | --- | --- | --- | --- | --- | --- | --- | --- | --- | --- | --- | --- | --- | --- | --- | --- | --- | --- | --- | --- | --- | --- | --- | --- | --- | --- | --- | --- | --- | --- | --- | --- |
|  | 3 | **1.3.1.1.2.3 HELIUM HEADERS** |  | 2009-03-25 | 2013-08-30 |  |  |  |  |  |  |  |  |  |  |  |  |  |  |  |  |  |  |  |  |  |  |  |  |  |  |  |  |  |  |  |  |  |  |
| 131123010 |  | Proc Helium Headers | 133d | 2009-03-25 A | 2009-09-30 A | 9-090M FS+120d | 100% |  |  | MECH DES [32 h]; MECH ENG [16 h] | 2,423.84 | 2,423.84 | 0 | 2423.84 | HOGAN J | 1 | 1 | H | JOHN H | 08-050 | 10-027 | 10-064 | 11-003 | 11-051 | 12-018F | 12-028F |  |  |  |  |  |  |  |  |  |  |  |  |  |
| 131123015 |  | Vend Fab - Helium Headers Lot #1, 2 & 3 (Phase 1) | 109d | 2009-09-14 A | 2010-02-25 A | 131123010 FS-1d | 100% |  |  | MECH DES [10 h]; MECH ENG [10 h]; PROCUREMENT>$50K 69; SR STAFF [10 h]; PROCUREMENT<$50K 60; SUPPLIES & MATERIALS; TRAVEL | 25,909.56 | 2,164.09 | 0 | 25850.36366 | HOGAN J | 1 | 1 | D | JOHN H | 08-050 | 10-027 | 10-064 | 11-003 | 11-051 | 12-018F |  | 0 | 21083.41 | 2108341 | 100 | APP |  |  |  |  |  |  |  |  |
| 131123016 |  | Vend Fab - Helium Headers Lot #1, 2 & 3 (Phase 2) FY09 Labor | 18d | 2010-02-01 A | 2010-02-25 A | 131123015 | 100% |  |  | SUPPLIES & MATERIALS; TRAVEL; MECH DES [13.88 h]; MECH ENG [13.88 h]; SR STAFF [13.88 h] | 6,708.46 | 3,014.88 | 0 | 6615.1812 | HOGAN J | 1 | 1 | D | JOHN H | 08-050 | 10-027 | 10-064 |  | 11-051 | 12-018F | 12-028F |  |  |  |  | APP | 08-052 | 09-017 | 10-001B | 10-066 | 11-012 |  |  |  |
| 131123016b |  | Vend Fab - Helium Headers Lot #1, 2 & 3 (Phase 2) FY10 Labor | 18d | 2010-02-01 A | 2010-02-25 A | 131123016 | 100% |  |  | SUPPLIES & MATERIALS; TRAVEL; MECH DES [16.12 h]; MECH ENG [16.12 h]; SR STAFF [16.12 h] | 7,930.9 | 3,501.42 | 0 | 7930.897226 | HOGAN J | 1 | 1 | D | JOHN H |  | 10-027 | 10-064 |  | 11-051 | 12-018F | 12-028F |  |  |  |  | APP |  |  | 10-001B | 10-066 | 11-012 |  |  |  |
| 131123016c |  | Vend Fab - Helium Headers Lot #1, 2 & 3 (Phase 2) Procurement | 21d | 2010-03-01 A | 2010-03-29 A | 131123015 | 100% |  |  | PROCUREMENT<$50K 60 NO ESCALATION FY10; PROCUREMENT>$50K 69 NO ESCALATION FY10 | 42,805.65 |  | 0 | 42805.65 | HOGAN J | 1 | 1 | D | JOHN H |  | 10-027 | 10-064 |  | 11-051 | 12-018F | 12-028F | 0 | 42805.65 | 4280565 | 100 | APP |  |  | 10-001B | 10-066 | 11-012 |  |  |  |
| 131123020 |  | Receive & Insp Helium Headers Lot #1 1-3 | 23d | 2010-03-29 A | 2010-04-28 A | 131123015, 131123010 | 100% |  |  | MECH ENG [12 h]; SUPPLIES & MATERIALS; MECH TECH [40 h]; MECH DES [8 h] | 3,371.11 | 2,821.72 | 0 | 3371.113879 | HOGAN J | 1 | 1 | H | JOHN H | 08-050 | 10-027 | 10-064 | 11-003 | 11-051 | 12-018F |  |  |  |  |  |  |  |  |  |  |  |  |  |  |
| 131123025 |  | Receive & Insp Helium Headers Lot #2 4-7 | 25d | 2010-05-24 A | 2010-06-28 A | 131123020, 131123015 FS-20d | 100% |  |  | SUPPLIES & MATERIALS; MECH TECH [40 h]; MECH DES [8 h]; MECH ENG [12 h] | 3,371.11 | 2,821.72 | 0 | 3371.113879 | HOGAN J | 1 | 1 | H | JOHN H | 08-050 | 10-027 | 10-064 |  | 11-051 | 12-018F | 12-028F |  |  |  |  |  |  |  |  | 10-066 | 11-012 |  |  |  |
| 131123030 |  | Receive & Insp Helium Headers Lot #3 8-10 | 27d | 2010-05-24 A | 2010-06-30 A | 131123025, 131123015 | 100% |  |  | MECH ENG [12 h]; SUPPLIES & MATERIALS; MECH DES [8 h] | 1,701.51 | 1,152.12 | 0 | 1701.513879 | HOGAN J | 1 | 1 | H | JOHN H | 08-050 | 10-027 | 10-064 |  |  | 12-018F | 12-028F |  |  |  |  |  |  |  |  | 10-066 |  |  |  |  |
| 131123016d |  | Vend Fab 10 CFR 851 Compliance | 1d | 2010-07-01 A | 2010-07-01 A | 131123010 FS+248d | 100% |  |  | PROCUREMENT>$50K 69 | 215,000 |  | 0 | 215000 | HOGAN J | 1 | 1 | D | JOHN H |  |  | 10-064 |  | 11-051 | 12-018F | 12-028F | 0 | 215000 | 21500000 | 100 | APP |  |  |  | 10-066 | 11-012 |  |  |  |
| 131123035 |  | Re-Baseline Actuals Adjustment | 1d | 2013-08-30 A | 2013-08-30 A |  | 100% | 2013-09-03 | 2013-09-03 | PROCUREMENT>$50K 69 NO ESCALATION | 4,148.99 |  |  | 4148.99 |  |  |  |  |  |  |  |  |  |  |  |  | 0 | 4148.99 | 414899 | 100 |  |  |  |  |  |  | ADJ |  |  |
|  | 3 | **1.3.1.1.3 CRYOMODULE PROCUREMENTS** |  | 2009-02-02 | 2013-08-30 |  |  |  |  |  |  |  |  |  |  |  |  |  |  |  |  |  |  |  |  |  |  |  |  |  |  |  |  |  |  |  |  |  |  |
|  | 1 | **1.3.1.1.3.1 MLI** |  | 2009-07-03 | 2013-08-30 |  |  |  |  |  |  |  |  |  |  |  |  |  |  |  |  |  |  |  |  |  |  |  |  |  |  |  |  |  |  |  |  |  |  |
| 131131010 |  | Proc MLI | 158d | 2009-07-03 A | 2010-02-25 A | 9-090M FS+98d | 100% | 2009-07-06 | 2010-02-25 | MECH DES [20 h]; MECH ENG [20 h] | 2,194.8 | 2,194.8 | 0 | 2153 | HOGAN J | 1 | 1 | H | JOHN H | 08-050 | 10-027 | 10-064 | 11-003 | 11-051 | 12-018F |  |  |  |  |  |  |  |  |  |  |  |  |  |  |
| 131131015 |  | Vend Fab - MLI (Phase 1) | 109d | 2009-09-14 A | 2010-02-25 A | 131131010 FS-500d | 100% |  |  | MECH ENG [10 h]; PROCUREMENT>$50K 69; SUPPLIES & MATERIALS; SR STAFF [10 h]; MECH DES [10 h]; MECH TECH [10 h]; PROCUREMENT<$50K 60 | 41,978.2 | 2,579.95 | 0 | 41907.65157 | HOGAN J | 1 | 1 | D | JOHN H | 08-050 | 10-027 | 10-064 | 11-003 | 11-051 | 12-018F |  | 0 | 38067.22 | 3806722 | 100 |  |  |  |  |  |  |  |  |  |
| 131131020 |  | Receive & Insp MLI (Phase 1) | 5d | 2009-12-14 A | 2009-12-21 A | 131131015 | 100% | 2009-12-14 | 2009-12-18 | SUPPLIES & MATERIALS; MECH TECH [10 h]; MECH DES [5 h]; MECH ENG [5 h] | 1,105.94 | 972.85 | 0 | 1075.844462 | HOGAN J | 1 | 1 | H | JOHN H | 08-050 | 10-027 | 10-064 | 11-003 | 11-051 | 12-018F |  |  |  |  |  |  |  | 09-017 |  |  |  |  |  |  |
| 131131016 |  | Vend Fab - MLI (Phase 2) | 101d | 2010-08-16 A | 2011-01-14 A | 131131015 | 100% |  |  | MECH DES [30 h]; MECH TECH [30 h]; PROCUREMENT<$50K 60; MECH ENG [30 h]; PROCUREMENT>$50K 69; SUPPLIES & MATERIALS; SR STAFF [30 h] | 126,130.09 | 7,935.34 | 0 | 125722.95471 | HOGAN J | 1 | 1 | D | JOHN H | 08-050 | 10-027 | 10-064 |  | 11-051 | 12-018F | 12-028F | 0 | 114201.69 | 11420169 | 100 |  |  | 09-017 |  | 10-066 | 11-012 |  |  |  |
| 131131021 |  | Receive & Insp MLI (Phase 2) FY09 | 18d | 2011-01-03 A | 2011-01-28 A | 131131016 | 100% | 2011-01-04 | 2011-01-28 | MECH DES [5.36 h]; MECH ENG [5.36 h]; SUPPLIES & MATERIALS; MECH TECH [10.71 h] | 1,218.3 | 1,075.69 | 0 | 1152.8335 | HOGAN J | 1 | 1 | H | JOHN H | 08-050 | 10-027 | 10-064 |  | 11-051 | 12-018F | 12-028F |  |  |  |  |  |  | 09-017 | 10-001B | 10-066 | 11-012 |  |  |  |
| 131131021b |  | Receive & Insp MLI (Phase 2) FY10 | 18d | 2011-01-03 A | 2011-01-28 A | 131131021 | 100% | 2011-01-04 | 2011-01-28 | MECH ENG [9.64 h]; SUPPLIES & MATERIALS; MECH TECH [19.29 h]; MECH DES [9.64 h] | 2,200.75 | 1,935.86 | 0 | 2140.96093 | HOGAN J | 1 | 1 | H | JOHN H |  | 10-027 | 10-064 |  | 11-051 | 12-018F | 12-028F |  |  |  |  |  |  |  | 10-001B | 10-066 | 11-012 |  |  |  |
| 131131025 |  | Re-Baseline Actuals Adjustment | 1d | 2013-08-30 A | 2013-08-30 A |  | 100% | 2013-09-03 | 2013-09-03 | PROCUREMENT>$50K 69 NO ESCALATION | -123,888.94 |  |  |  |  |  |  |  |  |  |  |  |  |  |  |  |  |  |  | 100 |  |  |  |  |  |  | ADJ |  |  |
|  | 2 | **1.3.1.1.3.2 THERMAL SHIELD** |  | 2009-03-25 | 2013-08-30 |  |  |  |  |  |  |  |  |  |  |  |  |  |  |  |  |  |  |  |  |  |  |  |  |  |  |  |  |  |  |  |  |  |  |
| 131132010 |  | Proc Thermal Shield | 126d | 2009-03-25 A | 2009-09-21 A | 9-090M FS+79d | 100% |  |  | MECH DES [20 h]; MECH ENG [20 h] | 2,153 | 2,153 | 0 | 2153 | HOGAN J | 1 | 1 | H | JOHN H | 08-050 | 10-027 | 10-064 | 11-003 | 11-051 | 12-018F |  |  |  |  |  |  |  |  |  |  |  |  |  |  |
| 131132015 |  | Vend Fab - Thermal Shield Lot #1 (Phase 1) Labor FY09 | 194d | 2009-09-14 A | 2010-06-28 A | 131132010 FS-1d | 100% | 2009-09-14 | 2010-06-25 | MECH ENG [4.2 h]; SR STAFF [2.1 h]; SUPPLIES & MATERIALS; TRAVEL; MECH DES [4.2 h] | 1,247.03 | 688.05 | 0 | 1227.124 | HOGAN J | 1 | 1 | D | JOHN H | 08-050 | 10-027 | 10-064 | 11-003 | 11-051 | 12-018F |  |  |  |  |  | APP |  |  | 10-001B |  |  |  | 09-012 |  |
| 131132015c |  | Vend Fab - Thermal Shield Lot #1 (Phase 1) Procurement | 195d | 2009-09-14 A | 2010-06-28 A | 131132010 FS-1d | 100% |  |  | PROCUREMENT>$50K 69 NO ESCALATION FY10; PROCUREMENT<$50K 60 NO ESCALATION FY10 | 122,986.43 |  | 0 | 122986.433955 | HOGAN J | 1 | 1 | D | JOHN H |  | 10-027 | 10-064 | 11-003 | 11-051 | 12-018F |  | 0 | 122986.43 | 12298643 | 100 | APP |  |  | 10-001B |  |  |  |  |  |
| 131132016 |  | Vend Fab - Thermal Shield Lot #2 & 3 (Phase 2) | 249d | 2010-01-04 A | 2011-01-04 A | 131132015c FS-100d, 131132015b FS-100d | 100% |  |  | PROCUREMENT>$50K 69; SUPPLIES & MATERIALS; TRAVEL; MECH DES [56 h]; MECH ENG [56 h]; SR STAFF [28 h]; PROCUREMENT<$50K 60 | 274,619.69 | 9,263.04 | 0 | 274549.045058 | HOGAN J | 1 | 1 | D | JOHN H | 08-050 | 10-027 | 10-064 |  | 11-051 | 12-018F | 12-028F | 0 | 257665.15139 | 25766515.139 | 100 | APP |  |  |  | 10-066 | 11-012 |  | 09-012 |  |
| 131132015b |  | Vend Fab - Thermal Shield Lot #1 (Phase 1) Labor FY10 | 104d | 2010-02-01 A | 2010-06-28 A | 131132015 FS-25d | 100% |  |  | MECH DES [19.8 h]; MECH ENG [19.8 h]; SR STAFF [9.9 h]; SUPPLIES & MATERIALS; TRAVEL | 5,969.66 | 3,250.17 | 0 | 5969.659898 | HOGAN J | 1 | 1 | D | JOHN H |  | 10-027 | 10-064 | 11-003 | 11-051 | 12-018F |  |  |  |  |  | APP |  |  | 10-001B |  |  |  |  |  |
| 131132020 |  | Receive & Insp Thermal Shield Lot #1 1-3 | 96d | 2010-02-15 A | 2010-06-30 A | 131132015b FS-25d, 131132015c FS-45d | 100% | 2010-02-16 | 2010-06-30 | MECH TECH [40 h]; SUPPLIES & MATERIALS; MECH DES [40 h]; MECH ENG [40 h] | 7,211.99 | 6,113.2 | 0 | 7211.987758 | HOGAN J | 1 | 1 | U | JOHN H | 08-050 | 10-027 | 10-064 | 11-003 | 11-051 | 12-018F |  |  |  |  |  |  |  |  |  |  |  |  |  |  |
| 131132025 |  | Receive & Insp Thermal Shield Lot #2 4-7 | 68d | 2010-08-23 A | 2010-11-29 A | 131132016 FS-60d, 131132020 | 100% |  |  | MECH TECH [40 h]; MECH DES [20 h]; MECH ENG [20 h]; SUPPLIES & MATERIALS | 5,063.13 | 3,964.34 | 0 | 4990.187758 | HOGAN J | 1 | 1 | U | JOHN H | 08-050 | 10-027 | 10-064 |  | 11-051 | 12-018F | 12-028F |  |  |  |  |  |  |  |  | 10-066 | 11-012 |  |  |  |
| 131132030 |  | Receive & Insp Thermal Shield Lot #3 8-10 FY10 | 7d | 2011-01-14 A | 2011-01-25 A | 131132025, 131132016 | 100% |  |  | MECH TECH [38.67 h]; MECH DES [19.33 h]; SUPPLIES & MATERIALS; MECH ENG [19.33 h] | 4,943.47 | 3,881.31 | 0 | 4823.6155 | HOGAN J | 1 | 1 | U | JOHN H | 08-050 | 10-027 | 10-064 |  |  | 12-018F | 12-028F |  |  |  |  |  |  |  |  | 10-066 |  |  |  | 11-001 |
| 131132030a |  | Receive & Insp Thermal Shield Lot #3 8-10 FY11 | 19d | 2011-02-01 A | 2011-02-28 A | 131132030 | 100% |  |  | MECH TECH [1.33 h]; MECH DES [0.67 h]; MECH ENG [0.67 h]; SUPPLIES & MATERIALS | 171.89 | 134.09 | 0 | 171.8852 | HOGAN J | 1 | 1 | U | JOHN H | 08-050 | 10-027 | 10-064 |  |  | 12-018F | 12-028F |  |  |  |  |  |  |  |  | 10-066 |  |  |  | 11-001 |
| 131132035 |  | Re-Baseline Actuals Adjustment | 1d | 2013-08-30 A | 2013-08-30 A |  | 100% | 2013-09-03 | 2013-09-03 | PROCUREMENT>$50K 69 NO ESCALATION | 33,224.83 |  |  | 33224.83 |  |  |  |  |  |  |  |  |  |  |  |  | 0 | 33224.83 | 3322483 | 100 |  |  |  |  |  |  | ADJ |  |  |

| ID | WBS | Activity | Duration | Start | Finish | Predecessors | Complete | Planned start | Planned finish | Resources | Cost | Actual cost | Calculated Remaining Total Cost | MONTHLY EV COST | RESP - Responsibility | STRT%COMP for CM EVM | FNSH%COMP for CM EVM | EVMS Reporting Codes | CAM RESPONSIBLE | CR 08-050 | CR 08-058 | CR 10-027 | CR 10-064 | CR 11-003 | CR 11-012 | CR 11-051 | CR 12-018 | Remaining Material Cost Based on % Compl | Claimed Material Cost Based on % Complet | Initial Claimed Material Calc | Claimed Material Divider | Advance Purchase Plan > 500K | CR 10-001 | CR 12-028 | CR 10-066 | LOE Divider | LOE Multiplier | CR 09-017 | LOE % Pre Calc | LOE % | CR 12-001 | ReBaseline Actuals Adjustment |
| --- | --- | --- | --- | --- | --- | --- | --- | --- | --- | --- | --- | --- | --- | --- | --- | --- | --- | --- | --- | --- | --- | --- | --- | --- | --- | --- | --- | --- | --- | --- | --- | --- | --- | --- | --- | --- | --- | --- | --- | --- | --- | --- |
|  | 3 | **1.3.1.1.3.3 MAGNETIC SHIELD** |  | 2009-06-22 | 2013-08-30 |  |  |  |  |  |  |  |  |  |  |  |  |  |  |  |  |  |  |  |  |  |  |  |  |  |  |  |  |  |  |  |  |  |  |  |  |  |
| 131133010 |  | Prcrmnt Prep for Magnetic Shield | 255d | 2009-06-22 A | 2010-06-30 A | 131133010XD | 100% |  |  | MECH ENG [6.44 h]; MECH DES [6.44 h] | 709.25 | 709.26 | 0 | 693.266 | HOGAN J | 1 | 1 | H | JOHN H | 08-050 | 08-058 | 10-027 | 10-064 | 11-003 | 11-012 | 11-051 | 12-018F |  |  |  |  |  |  |  |  |  |  |  |  |  |  |  |
| 131133015 |  | Vend Fab - Magnetic Shield Lot #1 (Phase 1) (FROZEN) | 34d | 2010-06-01 A | 2010-07-19 A | 131133010 FS-1d | 100% |  |  | PROCUREMENT<$50K 60; SR STAFF [12 h]; PROCUREMENT>$50K 69; MECH ENG [12 h]; SUPPLIES & MATERIALS; TRAVEL; MECH DES [12 h] | 91,750.92 | 2,606.52 | 0 | 91670.27634 | HOGAN J | 1 | 1 | D | JOHN H | 08-050 |  | 10-027 | 10-064 | 11-003 | 11-012 | 11-051 | 12-018F | 0 | 85949.94 | 8594994 | 100 | APP |  |  |  |  |  |  |  |  |  |  |
| 131133016 |  | Vend Fab - Magnetic Shield Lot #2 & 3 (Phase 2) Labor FY09 | 31d | 2010-06-01 A | 2010-07-14 A | 131133015 FS-53d | 100% |  |  | MECH DES [2.8 h]; SR STAFF [2.8 h]; MECH ENG [2.8 h]; SUPPLIES & MATERIALS; TRAVEL | 1,353.55 | 608.19 | 0 | 1334.732 | HOGAN J | 1 | 1 | D | JOHN H | 08-050 |  | 10-027 | 10-064 | 11-003 | 11-012 | 11-051 | 12-018F |  |  |  |  | APP | 10-001B |  |  |  |  |  |  |  |  |  |
| 131133016b |  | Vend Fab - Magnetic Shield Lot #2 & 3 (Phase 2) Labor FY10 | 34d | 2010-06-01 A | 2010-07-19 A | 131133016 | 100% |  |  | MECH ENG [25.2 h]; SUPPLIES & MATERIALS; TRAVEL; MECH DES [25.2 h]; SR STAFF [25.2 h] | 12,396.05 | 5,473.69 | 0 | 12396.048684 | HOGAN J | 1 | 1 | D | JOHN H |  |  | 10-027 | 10-064 | 11-003 | 11-012 | 11-051 | 12-018F |  |  |  |  | APP | 10-001B |  |  |  |  |  |  |  |  |  |
| 131133016c |  | Vend Fab - Inner Magnetic Shield- First Article Set | 21d | 2010-07-01 A | 2010-07-30 A | 131133015 FS-54d | 100% |  |  | PROCUREMENT<$50K 60 NO ESCALATION | 22,615 |  | 0 | 22615 | HOGAN J | 1 | 1 | D | JOHN H |  |  | 10-027 | 10-064 | 11-003 | 11-012 | 11-051 |  | 0 | 22615 | 2261500 | 100 | APP | 10-001B |  |  |  |  |  |  |  |  |  |
| 131133016c1 |  | Vend Fab - Inner Magnetic Shield Set #2 | 64d | 2010-07-01 A | 2010-09-30 A | 131133016c FS-43d | 100% |  |  | PROCUREMENT<$50K 60 NO ESCALATION | 20,258 |  | 0 | 20258 | HOGAN J | 1 | 1 | D | JOHN H |  |  | 10-027 | 10-064 | 11-003 | 11-012 | 11-051 |  | 0 | 20258 | 2025800 | 100 | APP |  |  |  |  |  |  |  |  |  |  |
| 131133017 |  | Vend Fab - Inner Magnetic Shield Set #3 | 81d | 2010-07-01 A | 2010-10-25 A | 131133016c1 FS-64d | 100% |  |  | PROCUREMENT>$50K 69 NO ESCALATION; PROCUREMENT<$50K 60 NO ESCALATION | 20,258 |  | 0 | 20258 | HOGAN J | 1 | 1 | D | JOHN H |  |  |  | 10-064 | 11-003 | 11-012 | 11-051 | 12-018F | 0 | 20258 | 2025800 | 100 | APP |  | 12-028F |  |  |  |  |  |  |  |  |
| 131133017A |  | Vend Fab - Inner Magnetic Shield Set #4 | 81d | 2010-07-01 A | 2010-10-25 A | 131133017 FS-105d | 100% |  |  | PROCUREMENT>$50K 69 NO ESCALATION | 20,258 |  | 0 | 20258 | HOGAN J | 1 | 1 | D | JOHN H |  |  |  | 10-064 | 11-003 | 11-012 | 11-051 | 12-018F | 0 | 20258 | 2025800 | 100 | APP |  | 12-028F | 10-066 |  |  |  |  |  |  |  |
| 131133017B |  | Vend Fab - Inner Magnetic Shield Set #5 | 105d | 2010-07-01 A | 2010-11-30 A | 131133017A FS-105d | 100% |  |  | PROCUREMENT>$50K 69 NO ESCALATION | 20,258 |  | 0 | 20258 | HOGAN J | 1 | 1 | D | JOHN H |  |  |  | 10-064 | 11-003 | 11-012 | 11-051 | 12-018F | 0 | 20258 | 2025800 | 100 | APP |  | 12-028F | 10-066 |  |  |  |  |  |  |  |
| 131133017C |  | Vend Fab - Inner Magnetic Shield Set #6 | 142d | 2010-07-01 A | 2011-01-31 A | 131133017B FS-122d | 100% |  |  | PROCUREMENT>$50K 69 NO ESCALATION | 20,258 |  | 0 | 20258 | HOGAN J | 1 | 1 | D | JOHN H |  |  |  | 10-064 | 11-003 | 11-012 | 11-051 | 12-018F | 0 | 20258 | 2025800 | 100 | APP |  |  | 10-066 |  |  |  |  |  |  |  |
| 131133017D |  | Vend Fab - Inner Magnetic Shield Set #7 | 180d | 2010-07-01 A | 2011-03-25 A | 131133017C FS-142d | 100% |  |  | PROCUREMENT>$50K 69 NO ESCALATION | 20,258 |  | 0 | 20258 | HOGAN J | 1 | 1 | D | JOHN H |  |  |  | 10-064 |  |  |  | 12-018F | 0 | 20258 | 2025800 | 100 | APP |  | 12-028F | 10-066 |  |  |  |  |  |  |  |
| 131133017F |  | Vend Fab - Inner Magnetic Shield Set #8 | 180d | 2010-07-01 A | 2011-03-25 A | 131133017D FS-161d | 100% |  |  | PROCUREMENT>$50K 69 NO ESCALATION | 20,258 |  | 0 | 20258 | HOGAN J | 1 | 1 | D | JOHN H |  |  |  | 10-064 |  |  |  | 12-018F | 0 | 20258 | 2025800 | 100 | APP |  | 12-028F | 10-066 |  |  |  |  |  |  |  |
| 131133017G |  | Vend Fab - Inner Magnetic Shield Set #9 | 201d | 2010-07-01 A | 2011-04-25 A | 131133017F FS-184d | 100% |  |  | PROCUREMENT>$50K 69 NO ESCALATION | 20,258 |  | 0 | 20258 | HOGAN J | 1 | 1 | D | JOHN H |  |  |  | 10-064 |  |  |  | 12-018F | 0 | 20258 | 2025800 | 100 | APP |  | 12-028F | 10-066 |  |  |  |  |  |  |  |
| 131133017H |  | Vend Fab - Inner Magnetic Shield Set #10 | 240d | 2010-07-01 A | 2011-06-20 A | 131133017G FS-205d | 100% |  |  | PROCUREMENT>$50K 69 NO ESCALATION | 20,258 |  | 0 | 20258 | HOGAN J | 1 | 1 | D | JOHN H |  |  |  | 10-064 |  |  |  | 12-018F | 0 | 20258 | 2025800 | 100 | APP |  | 12-028F | 10-066 |  |  |  |  |  |  |  |
| 131133018 |  | Vend Fab - Outer Magnetic Shield First Article Set | 64d | 2010-07-01 A | 2010-09-30 A | 131133015 FS-54d | 100% |  |  | PROCUREMENT<$50K 60 NO ESCALATION | 18,933 |  | 0 | 18933 | HOGAN J | 1 | 1 | D | JOHN H |  |  |  | 10-064 | 11-003 | 11-012 | 11-051 | 12-018F | 0 | 18933 | 1893300 | 100 | APP |  |  |  |  |  |  |  |  |  |  |
| 131133018A |  | Vend Fab - Outer Magnetic Shield Receipt of Materials | 215d | 2010-07-01 A | 2011-05-15 A | 131133018 FS-85d | 100% | 2010-07-01 | 2011-05-13 | PROCUREMENT<$50K 60 NO ESCALATION; PROCUREMENT>$50K 69 NO ESCALATION | 62,881.43 |  | 0 | 62881.43 | HOGAN J | 1 | 1 | D | JOHN H |  |  |  | 10-064 | 11-003 | 11-012 | 11-051 | 12-018F | 0 | 62881.43 | 6288143 | 100 | APP |  |  |  |  |  |  |  |  |  |  |
| 131133018B |  | Vend Fab - Outer Magnetic Shield Set #2 | 216d | 2010-07-01 A | 2011-05-16 A | 131133018A FS-122d | 100% |  |  | PROCUREMENT>$50K 69 NO ESCALATION | 10,517.13 |  | 0 | 10517.13 | HOGAN J | 1 | 1 | D | JOHN H |  |  |  | 10-064 | 11-003 | 11-012 | 11-051 | 12-018F | 0 | 10517.13 | 1051713 | 100 | APP |  |  |  |  |  |  |  |  |  |  |
| 131133018C |  | Vend Fab - Outer Magnetic Shield Set #3 | 239d | 2010-07-01 A | 2011-06-18 A | 131133018B FS-122d | 100% | 2010-07-01 | 2011-06-17 | PROCUREMENT>$50K 69 NO ESCALATION | 10,517.13 |  | 0 | 10517.13 | HOGAN J | 1 | 1 | D | JOHN H |  |  |  | 10-064 | 11-003 | 11-012 | 11-051 | 12-018F | 0 | 10517.13 | 1051713 | 100 | APP |  | 12-028F |  |  |  |  |  |  |  |  |
| 131133018D |  | Vend Fab - Outer Magnetic Shield Set #4 | 275d | 2010-07-01 A | 2011-08-09 A | 131133018C FS-161d | 100% |  |  | PROCUREMENT>$50K 69 NO ESCALATION | 10,517.13 |  | 0 | 10517.13 | HOGAN J | 1 | 1 | D | JOHN H |  |  |  | 10-064 |  | 11-012 | 11-051 | 12-018F | 0 | 10517.13 | 1051713 | 100 | APP |  | 12-028F | 10-066 |  |  |  |  |  |  |  |
| 131133018F |  | Vend Fab - Outer Magnetic Shield Set #5 | 298d | 2010-07-01 A | 2011-09-12 A | 131133018D FS-184d | 100% |  |  | PROCUREMENT>$50K 69 NO ESCALATION | 10,517.13 |  | 0 | 10517.13 | HOGAN J | 1 | 1 | D | JOHN H |  |  |  | 10-064 |  | 11-012 | 11-051 | 12-018F | 0 | 10517.13 | 1051713 | 100 | APP |  | 12-028F | 10-066 |  |  |  |  |  |  |  |
| 131133018G |  | Vend Fab - Outer Magnetic Shield Set #6 | 384d | 2010-07-01 A | 2012-01-23 A | 131133018F FS-205d | 100% |  |  | PROCUREMENT>$50K 69 NO ESCALATION | 10,517.13 |  | 0 | 10517.13 | HOGAN J | 1 | 1 | D | JOHN H |  |  |  | 10-064 |  | 11-012 | 11-051 | 12-018F | 0 | 10517.13 | 1051713 | 100 | APP |  |  | 10-066 |  |  |  |  |  |  |  |
| 131133018H |  | Vend Fab - Outer Magnetic Shield Set #7 | 404d | 2010-07-01 A | 2012-02-21 A | 131133018G FS-226d | 100% |  |  | PROCUREMENT>$50K 69 NO ESCALATION | 10,517.13 |  | 0 | 10517.13 | HOGAN J | 1 | 1 | D | JOHN H |  |  |  | 10-064 |  |  | 11-051 | 12-018F | 0 | 10517.13 | 1051713 | 100 | APP |  | 12-028F | 10-066 |  |  |  |  |  |  |  |
| 131133018J |  | Vend Fab - Outer Magnetic Shield Set #8 | 403d | 2010-07-01 A | 2012-02-20 A | 131133018H FS-248d | 100% | 2010-07-01 | 2012-02-17 | PROCUREMENT>$50K 69 NO ESCALATION | 10,517.13 |  | 0 | 10517.13 | HOGAN J | 1 | 1 | D | JOHN H |  |  |  | 10-064 |  |  | 11-051 | 12-018F | 0 | 10517.13 | 1051713 | 100 | APP |  | 12-028F | 10-066 |  |  |  |  |  |  |  |
| 131133018K |  | Vend Fab - Outer Magnetic Shield Set #9 | 486d | 2010-07-01 A | 2012-06-18 A | 131133018J FS-268d | 100% |  |  | PROCUREMENT>$50K 69 NO ESCALATION | 10,517.13 |  | 0 | 10517.13 | HOGAN J | 1 | 1 | D | JOHN H |  |  |  | 10-064 |  |  | 11-051 | 12-018F | 0 | 10517.13 | 1051713 | 100 | APP |  | 12-028F | 10-066 |  |  |  |  |  |  |  |
| 131133018L |  | Vend Fab - Outer Magnetic Shield Set #10 | 505d | 2010-07-01 A | 2012-07-16 A | 131133018K FS-291d | 100% | 2010-07-01 | 2012-07-13 | PROCUREMENT>$50K 69 NO ESCALATION | 10,517.13 |  | 0 | 10517.13 | HOGAN J | 1 | 1 | D | JOHN H |  |  |  | 10-064 |  |  | 11-051 | 12-018F | 0 | 10517.13 | 1051713 | 100 | APP |  | 12-028F | 10-066 |  |  |  |  |  |  |  |
| 131133120LOE |  | SOTR Oversight FY10 | 64d | 2010-07-01 A | 2010-09-30 A | 9-100M FS+184d | 100% |  |  | MECH ENG [52 h] | 3,424.2 | 3,424.2 | 0 | 3424.2 | HOGAN J | 1 | 1 | E | JOHN H |  |  |  | 10-064 |  |  | 11-051 | 12-018F |  |  |  |  |  |  | 12-028F | 10-066 | 100 | 100 |  |  |  |  |  |
| 131133015a |  | Vend Fab - Magnetic Shield Lot #1 (Phase 1) Reverse Entry Per CR10-064 ETC | 6d | 2010-07-12 A | 2010-07-19 A | 9-100M FS+184d | 100% |  |  | MECH DES [-12 h]; SR STAFF [-12 h]; PROCUREMENT>$50K 69; MECH ENG [-12 h]; PROCUREMENT<$50K 60; SUPPLIES & MATERIALS; TRAVEL | -91,750.92 | -2,606.52 |  |  | HOGAN J | 1 | 1 | D | JOHN H | 08-050 |  | 10-027 | 10-064 | 11-003 | 11-012 | 11-051 |  |  |  |  | 100 | APP |  |  |  |  |  |  |  |  |  |  |
| 131133020 |  | Receive & Insp Inner Magnetic Shield First Article Set | 6d | 2010-08-02 A | 2010-08-09 A | 131133015 FS-54d, 131133016c FS-162d, 131133010 | 100% |  |  | MECH ENG [20 h]; SUPPLIES & MATERIALS; MECH TECH [40 h]; MECH DES [20 h] | 4,440.79 | 3,891.4 | 0 | 4440.793879 | HOGAN J | 1 | 1 | U | JOHN H | 08-050 |  | 10-027 | 10-064 | 11-003 |  | 11-051 | 12-018F |  |  |  |  |  |  |  |  |  |  | 09-017 |  |  |  |  |
| 131133025 |  | Receive & Insp Inner Magnetic Shield Set #2 | 21d | 2010-09-01 A | 2010-09-30 A | 131133016b FS-40d, 131133015a, 131133016c1 | 100% |  |  | MECH DES [8 h]; MECH TECH [40 h]; MECH ENG [8 h] | 2,558.32 | 2,558.32 | 0 | 2639.84 | HOGAN J | 1 | 1 | U | JOHN H | 08-050 |  | 10-027 | 10-064 | 11-003 | 11-012 | 11-051 |  |  |  |  |  |  |  |  |  |  |  | 09-017 |  |  |  |  |
| 131133070 |  | Receive & Insp Outer Magnetic Shield First Article Set | 142d | 2010-09-24 A | 2011-04-25 A | 131133018 | 100% |  |  | MECH TECH [40 h]; MECH DES [20 h]; MECH ENG [20 h]; SUPPLIES & MATERIALS | 4,577.96 | 4,011.04 | 0 | 4582.32 | HOGAN J | 1 | 1 | U | JOHN H |  |  |  | 10-064 | 11-003 |  | 11-051 | 12-018F |  |  |  |  |  |  |  |  |  |  |  |  |  |  |  |
| 131133125LOE |  | SOTR Oversight FY11 | 248d | 2010-10-01 A | 2011-09-30 A | 131133120LOE | 100% |  |  | MECH ENG [200 h] | 13,590 | 13,590 | 0 | 13590 | HOGAN J | 1 | 1 | E | JOHN H |  |  |  | 10-064 |  |  | 11-051 | 12-018F |  |  |  |  |  |  | 12-028F | 10-066 | 100 | 100 |  | 8.46774193 | 91.53225806 |  |  |
| 131133030 |  | Receive & Insp Inner Magnetic Shield Set #3 | 13d | 2010-10-07 A | 2010-10-25 A | 131133016b, 131133017 | 100% |  |  | MECH DES [8 h]; MECH ENG [8 h]; MECH TECH [40 h] | 2,639.84 | 2,639.84 | 0 | 2639.84 | HOGAN J | 1 | 1 | U | JOHN H | 08-050 |  | 10-027 | 10-064 | 11-003 | 11-012 | 11-051 | 12-018F |  |  |  |  |  |  | 12-028F |  |  |  | 09-017 |  |  |  |  |
| 131133035 |  | Receive & Insp Inner Magnetic Shield Set #4 | 13d | 2010-10-07 A | 2010-10-25 A | 131133017A | 100% |  |  | MECH DES [8 h]; MECH ENG [8 h]; MECH TECH [40 h] | 2,639.84 | 2,639.84 | 0 | 2639.84 | HOGAN J | 1 | 1 | U | JOHN H |  |  |  | 10-064 |  | 11-012 | 11-051 | 12-018F |  |  |  |  |  |  | 12-028F | 10-066 |  |  |  |  |  |  |  |
| 131133040 |  | Receive & Insp Inner Magnetic Shield Set #5 | 9d | 2011-01-04 A | 2011-01-14 A | 131133017B | 100% |  |  | MECH DES [8 h]; MECH ENG [8 h]; MECH TECH [40 h] | 2,639.84 | 2,639.84 | 0 | 2639.84 | HOGAN J | 1 | 1 | U | JOHN H |  |  |  | 10-064 |  | 11-012 | 11-051 | 12-018F |  |  |  |  |  |  | 12-028F | 10-066 |  |  |  |  |  |  |  |
| 131133045 |  | Receive & Insp Inner Magnetic Shield Set #6 | 9d | 2011-01-17 A | 2011-01-28 A | 131133017C | 100% | 2011-01-18 | 2011-01-28 | MECH ENG [8 h]; MECH TECH [40 h]; MECH DES [8 h] | 2,639.84 | 2,639.84 | 0 | 2639.84 | HOGAN J | 1 | 1 | U | JOHN H | 08-050 |  |  | 10-064 |  | 11-012 | 11-051 | 12-018F |  |  |  |  |  |  |  | 10-066 |  |  | 09-017 |  |  |  |  |
| 131133050 |  | Receive & Insp Inner Magnetic Shield Set #7 | 18d | 2011-03-02 A | 2011-03-25 A | 131133017D | 100% |  |  | MECH TECH [40 h]; MECH DES [8 h]; MECH ENG [8 h] | 2,639.84 | 2,639.84 | 0 | 2639.84 | HOGAN J | 1 | 1 | U | JOHN H |  |  |  | 10-064 |  |  |  | 12-018F |  |  |  |  |  |  | 12-028F | 10-066 |  |  |  |  |  |  |  |
| 131133055 |  | Receive & Insp Inner Magnetic Shield Set #8 | 18d | 2011-03-02 A | 2011-03-25 A | 131133017F | 100% |  |  | MECH DES [8 h]; MECH ENG [8 h]; MECH TECH [40 h] | 2,639.84 | 2,639.84 | 0 | 2639.84 | HOGAN J | 1 | 1 | U | JOHN H |  |  |  | 10-064 |  |  |  | 12-018F |  |  |  |  |  |  | 12-028F | 10-066 |  |  |  |  |  |  |  |
| 131133060 |  | Receive & Insp Inner Magnetic Shield Set #9 | 17d | 2011-04-01 A | 2011-04-25 A | 131133017G | 100% |  |  | MECH DES [8 h]; MECH ENG [8 h]; MECH TECH [40 h] | 2,639.84 | 2,639.84 | 0 | 2639.84 | HOGAN J | 1 | 1 | U | JOHN H |  |  |  | 10-064 |  |  |  | 12-018F |  |  |  |  |  |  | 12-028F | 10-066 |  |  |  |  |  |  |  |
| 131133075 |  | Receive & Insp Outer Magnetic Shield Set #2 | 9d | 2011-05-11 A | 2011-05-23 A | 131133018B FS-5d | 100% |  |  | MECH ENG [8 h]; MECH TECH [40 h]; MECH DES [8 h] | 2,639.84 | 2,639.84 | 0 | 2639.84 | HOGAN J | 1 | 1 | U | JOHN H |  |  |  | 10-064 | 11-003 | 11-012 | 11-051 |  |  |  |  |  |  |  |  |  |  |  |  |  |  |  |  |
| 131133065 |  | Receive & Insp Inner Magnetic Shield Set #10 | 1d | 2011-06-19 A | 2011-06-20 A | 131133017H | 100% | 2011-06-20 | 2011-06-20 | MECH DES [8 h]; MECH ENG [8 h]; MECH TECH [40 h] | 2,639.84 | 2,639.84 | 0 | 2639.84 | HOGAN J | 1 | 1 | U | JOHN H |  |  |  | 10-064 |  |  |  | 12-018F |  |  |  |  |  |  | 12-028F | 10-066 |  |  |  |  |  |  |  |
| 131133080 |  | Receive & Insp Outer Magnetic Shield Set #3 | 6d | 2011-06-19 A | 2011-06-27 A | 131133018C | 100% | 2011-06-20 | 2011-06-27 | MECH ENG [8 h]; MECH TECH [40 h]; MECH DES [8 h] | 2,639.84 | 2,639.84 | 0 | 2639.84 | HOGAN J | 1 | 1 | U | JOHN H |  |  |  | 10-064 | 11-003 | 11-012 | 11-051 | 12-018F |  |  |  |  |  |  | 12-028F |  |  |  |  |  |  |  |  |
| 131133085 |  | Receive & Insp Outer Magnetic Shield Set #4 | 7d | 2011-09-01 A | 2011-09-12 A | 131133018D | 100% |  |  | MECH DES [8 h]; MECH ENG [8 h]; MECH TECH [40 h] | 2,639.84 | 2,639.84 | 0 | 2639.84 | HOGAN J | 1 | 1 | U | JOHN H |  |  |  | 10-064 |  | 11-012 | 11-051 | 12-018F |  |  |  |  |  |  | 12-028F | 10-066 |  |  |  |  |  |  |  |
| 131133090 |  | Receive & Insp Outer Magnetic Shield Set #5 | 14d | 2011-09-13 A | 2011-09-30 A | 131133018F | 100% |  |  | MECH DES [8 h]; MECH ENG [8 h]; MECH TECH [40 h] | 2,639.84 | 2,639.84 | 0 | 2639.84 | HOGAN J | 1 | 1 | U | JOHN H |  |  |  | 10-064 |  | 11-012 | 11-051 | 12-018F |  |  |  |  |  |  | 12-028F | 10-066 |  |  |  |  |  |  |  |
| 131133130LOE |  | SOTR Oversight FY12 | 16d | 2011-10-03 A | 2011-10-24 A | 131133125LOE | 100% |  |  | MECH ENG [20 h] | 1,402.4 | 1,402.4 | 0 | 1402.4 | HOGAN J | 1 | 1 | E | JOHN H |  |  |  | 10-064 |  |  | 11-051 | 12-018F |  |  |  |  |  |  | 12-028F | 10-066 | 100 | 100 |  | 100 | 0 |  |  |
| 131133095 |  | Receive & Insp Outer Magnetic Shield Set #6 | 6d | 2012-01-23 A | 2012-01-30 A | 131133018G | 100% |  |  | MECH DES [8 h]; MECH ENG [8 h]; MECH TECH [40 h] | 2,723.92 | 2,723.92 | 0 | 2639.84 | HOGAN J | 1 | 1 | U | JOHN H |  |  |  | 10-064 |  | 11-012 | 11-051 | 12-018F |  |  |  |  |  |  |  | 10-066 |  |  |  |  |  |  |  |
| 131133100 |  | Receive & Insp Outer Magnetic Shield Set #7 | 5d | 2012-02-13 A | 2012-02-20 A | 131133018H | 100% | 2012-02-13 | 2012-02-17 | MECH DES [8 h]; MECH ENG [8 h]; MECH TECH [40 h] | 2,723.92 | 2,723.92 | 0 | 2639.84 | HOGAN J | 1 | 1 | U | JOHN H |  |  |  | 10-064 |  |  | 11-051 | 12-018F |  |  |  |  |  |  | 12-028F | 10-066 |  |  |  |  |  |  |  |
| 131133105 |  | Receive & Insp Outer Magnetic Shield Set #8 | 12d | 2012-03-02 A | 2012-03-19 A | 131133018J | 100% |  |  | MECH DES [8 h]; MECH ENG [8 h]; MECH TECH [40 h] | 2,723.92 | 2,723.92 | 0 | 2639.84 | HOGAN J | 1 | 1 | U | JOHN H |  |  |  | 10-064 |  |  | 11-051 | 12-018F |  |  |  |  |  |  | 12-028F | 10-066 |  |  |  |  |  |  |  |
| 131133110 |  | Receive & Insp Outer Magnetic Shield Set #9 | 5d | 2012-06-19 A | 2012-06-25 A | 131133018K | 100% |  |  | MECH DES [8 h]; MECH ENG [8 h]; MECH TECH [40 h] | 2,723.92 | 2,723.92 | 0 | 2639.84 | HOGAN J | 1 | 1 | U | JOHN H |  |  |  | 10-064 |  |  | 11-051 | 12-018F |  |  |  |  |  |  | 12-028F | 10-066 |  |  |  |  |  |  |  |
| 131133115 |  | Receive & Insp Outer Magnetic Shield Set #10 FY11 | 5d | 2012-07-02 A | 2012-07-09 A | 131133018L | 100% | 2012-07-02 | 2012-07-06 | MECH ENG [1.6 h]; MECH TECH [8 h]; MECH DES [1.6 h] | 544.78 | 544.78 | 0 | 527.968 | HOGAN J | 1 | 1 | U | JOHN H |  |  |  | 10-064 |  |  | 11-051 | 12-018F |  |  |  |  |  |  | 12-028F | 10-066 |  |  |  |  |  | 12-001 |  |
| 131133115a |  | Receive & Insp Outer Magnetic Shield Set #10 FY12 | 9d | 2012-07-10 A | 2012-07-23 A | 131133115 | 100% | 2012-07-10 | 2012-07-20 | MECH DES [6.4 h]; MECH TECH [32 h]; MECH ENG [6.4 h] | 2,179.14 | 2,179.14 | 0 | 2179.136 | HOGAN J | 1 | 1 | U | JOHN H | 08-050 |  | 10-027 | 10-064 |  |  | 11-051 | 12-018F |  |  |  |  |  |  | 12-028F | 10-066 |  |  | 09-017 |  |  | 12-001 |  |
| 131133135 |  | Re-Baseline Actuals Adjustment | 1d | 2013-08-30 A | 2013-08-30 A |  | 100% | 2013-09-03 | 2013-09-03 | PROCUREMENT>$50K 69 NO ESCALATION | 103,024.98 |  |  | 103024.98 |  |  |  |  |  |  |  |  |  |  |  |  |  | 0 | 103024.98 | 10302498 | 100 |  |  |  |  |  |  |  |  |  |  | ADJ |

| ID | WBS | Activity | Duration | Start | Finish | Predecessors | Complete | Planned start | Planned finish | Resources | Cost | Actual cost | Calculated Remaining Total Cost | MONTHLY EV COST | RESP - Responsibility | STRT%COMP for CM EVM | FNSH%COMP for CM EVM | EVMS Reporting Codes | CAM RESPONSIBLE | CR 08-050 | CR 10-027 | CR 10-064 | CR 11-003 | CR 11-051 | CR 12-018 | Advance Purchase Plan > 500K | CR 09-012 | CR 10-001 | Remaining Material Cost Based on % Compl | Claimed Material Cost Based on % Complet | Initial Claimed Material Calc | Claimed Material Divider | CR 09-017 | CR 10-012 | CR 10-066 | CR 11-012 | CR 12-028 | LOE Divider | LOE Multiplier | ReBaseline Actuals Adjustment | 12 GEV MAJOR PROCUREMENT CATAGORY | CR 10-018 | CR 11-001 | LOE % Pre Calc | LOE % |
| --- | --- | --- | --- | --- | --- | --- | --- | --- | --- | --- | --- | --- | --- | --- | --- | --- | --- | --- | --- | --- | --- | --- | --- | --- | --- | --- | --- | --- | --- | --- | --- | --- | --- | --- | --- | --- | --- | --- | --- | --- | --- | --- | --- | --- | --- |
|  | 4 | **1.3.1.1.3.4 INSTRUMENTATION** |  | 2009-06-22 | 2013-08-30 |  |  |  |  |  |  |  |  |  |  |  |  |  |  |  |  |  |  |  |  |  |  |  |  |  |  |  |  |  |  |  |  |  |  |  |  |  |  |  |  |
| 131134010 |  | Proc Instrmenttn | 229d | 2009-06-22 A | 2010-05-24 A | 9-090M FS+120d | 100% |  |  | MECH DES [20 h] | 896.12 | 896.12 | 0 | 876.8 | HOGAN J | 1 | 1 | H | JOHN H | 08-050 | 10-027 | 10-064 | 11-003 | 11-051 | 12-018F |  |  |  |  |  |  |  |  |  |  |  |  |  |  |  |  |  |  |  |  |
| 131134012 |  | Vend Fab - Instrmenttn (Phase 1) Labor FY09 | 65d | 2009-11-09 A | 2010-02-19 A | 131134010 FS-250d | 100% |  |  | SR STAFF [6.4 h]; ELEC ENG [6.4 h]; ELEC TECH [12.8 h]; MECH DES [6.4 h]; MECH ENG [6.4 h] | 2,344.84 | 2,344.84 | 0 | 2272.384 | HOGAN J | 1 | 1 | D | JOHN H | 08-050 | 10-027 | 10-064 | 11-003 | 11-051 | 12-018F | APP | 09-012 | 10-001B |  |  |  |  |  |  |  |  |  |  |  |  |  |  |  |  |  |
| 131134012b |  | Vend Fab - Instrmenttn (Phase 1) Labor FY10 | 65d | 2009-11-09 A | 2010-02-19 A | 131134012 FS-200d | 100% |  |  | SR STAFF [5.6 h]; ELEC ENG [5.6 h]; ELEC TECH [11.2 h]; MECH DES [5.6 h]; MECH ENG [5.6 h] | 2,051.72 | 2,051.72 | 0 | 2051.728 | HOGAN J | 1 | 1 | D | JOHN H |  | 10-027 | 10-064 | 11-003 | 11-051 | 12-018F | APP |  | 10-001B |  |  |  |  |  |  |  |  |  |  |  |  |  |  |  |  |  |
| 131134012c |  | Vend Fab - Instrmenttn (Phase 1) Procurement | 65d | 2009-11-09 A | 2010-02-19 A | 131134010 FS-200d | 100% |  |  | PROCUREMENT>$50K 69 NO ESCALATION FY10 | 81,139.1 |  | 0 | 81139.101882 | HOGAN J | 1 | 1 | D | JOHN H |  | 10-027 | 10-064 | 11-003 | 11-051 | 12-018F | APP |  | 10-001B | 0 | 81139.1 | 8113910 | 100 |  |  |  |  |  |  |  |  |  |  |  |  |  |
| 131134015 |  | Receive & Insp Instrmenttn (Phase 1) | 8d | 2010-02-15 A | 2010-02-25 A | 131134010, 131134012c, 131134012b | 100% | 2010-02-16 | 2010-02-25 | ELEC TECH [24 h]; MECH DES [6 h]; ELEC ENG [12 h]; SUPPLIES & MATERIALS | 3,709.66 | 2,061.48 | 0 | 3709.661637 | HOGAN J | 1 | 1 | H | JOHN H | 08-050 | 10-027 | 10-064 | 11-003 | 11-051 | 12-018F |  |  |  |  |  |  |  |  |  |  |  |  |  |  |  |  |  |  |  |  |
| 131134013 |  | Vend Fab - Instrmenttn (Phase 2) | 293d | 2010-02-22 A | 2011-04-25 A | 9-100M, 131134012b, 131134012c | 100% |  |  | ELEC TECH [56 h]; MECH DES [28 h]; MECH ENG [28 h]; SR STAFF [28 h]; PROCUREMENT>$50K 69; ELEC ENG [28 h] | 405,775.56 | 10,411.54 | 0 | 405622.66 | HOGAN J | 1 | 1 | D | JOHN H | 08-050 | 10-027 | 10-064 |  | 11-051 | 12-018F | APP |  |  | 0 | 395364.02 | 39536402 | 100 | 09-017 | 10-012 | 10-066 | 11-012 | 12-028F |  |  |  |  |  |  |  |  |
| 131134016 |  | Receive & Insp Instrmenttn (Phase 2) | 134d | 2010-02-22 A | 2010-08-30 A | 131134013 FS-60d | 100% |  |  | ELEC ENG [28 h]; ELEC TECH [56 h]; MECH DES [14 h]; SUPPLIES & MATERIALS | 8,655.87 | 4,810.12 | 0 | 8655.866834 | HOGAN J | 1 | 1 | H | JOHN H | 08-050 | 10-027 | 10-064 |  | 11-051 | 12-018F |  |  |  |  |  |  |  | 09-017 |  | 10-066 | 11-012 | 12-028F |  |  |  |  |  |  |  |  |
| 131134021LOE |  | SOTR Oversight | 64d | 2010-07-01 A | 2010-09-30 A | 9-100M FS+184d | 100% |  |  | MECH DES [80 h]; ELEC ENG [200 h]; ELEC TECH [320 h] | 30,137.2 | 30,137.2 | 0 | 30137.2 | HOGAN J | 1 | 1 | E | JOHN H |  |  | 10-064 |  | 11-051 | 12-018F |  |  |  |  |  |  |  |  |  | 10-066 | 11-012 | 12-028F | 100 | 100 |  |  |  |  |  |  |
| 131134018 |  | Receive & Insp Instrmenttn (Phase 2) Additional Hardware | 165d | 2010-08-23 A | 2011-04-25 A | 131134016 FS-60d | 100% |  |  | ELEC TECH [56 h]; MECH DES [14 h]; SUPPLIES & MATERIALS; ELEC ENG [28 h] | 8,783.04 | 4,937.29 | 0 | 8655.866834 | HOGAN J | 1 | 1 | H | JOHN H |  |  | 10-064 |  | 11-051 | 12-018F |  |  |  |  |  |  |  |  |  | 10-066 | 11-012 | 12-028F |  |  |  |  |  |  |  |  |
| 131134025 |  | Re-Baseline Actuals Adjustment | 1d | 2013-08-30 A | 2013-08-30 A |  | 100% | 2013-09-03 | 2013-09-03 | PROCUREMENT>$50K 69 NO ESCALATION | 459,231.19 |  |  | 459231.19 |  |  |  |  |  |  |  |  |  |  |  |  |  |  | 0 | 459231.19 | 45923119 | 100 |  |  |  |  |  |  |  | ADJ |  |  |  |  |  |
|  | 5 | **1.3.1.1.3.5 END CANS** |  | 2009-06-22 | 2013-08-30 |  |  |  |  |  |  |  |  |  |  |  |  |  |  |  |  |  |  |  |  |  |  |  |  |  |  |  |  |  |  |  |  |  |  |  |  |  |  |  |  |
| 131135010 |  | Proc End Cans | 126d | 2009-06-22 A | 2009-12-23 A | 1211020M10 FS-100d | 100% | 2009-06-22 | 2009-12-18 | MECH DES [20 h]; MECH ENG [20 h] | 2,183.03 | 2,183.03 | 0 | 2221.8 | HOGAN J | 1 | 1 | H | JOHN H | 08-050 |  |  |  |  |  |  |  |  |  |  |  |  | 09-017 |  |  |  |  |  |  |  |  |  |  |  |  |
| 131135015B |  | Vend Fab End Cans - Submittal of Project Q.A. Plan | 29d | 2010-01-04 A | 2010-02-15 A | 131135010 FS-21d | 100% | 2010-01-04 | 2010-02-12 | PROCUREMENT>$50K 69 NO ESCALATION; PROCUREMENT<$50K 60 NO ESCALATION | 67,645 |  | 0 | 67645 | HOGAN J | 1 | 1 | P | JOHN H |  | 10-027 | 10-064 | 11-003 | 11-051 |  | APP |  |  | 0 | 67645 | 6764500 | 100 |  |  |  |  |  |  |  |  | 3113A | 10-018 |  |  |  |
| 131135015C |  | Vend Fab End Cans - Material P.O. for End Can sets 1-3 | 59d | 2010-01-04 A | 2010-03-29 A | 131135015B FS-19d | 100% |  |  | PROCUREMENT>$50K 69 NO ESCALATION | 174,599 |  | 0 | 174599 | HOGAN J | 1 | 1 | P | JOHN H |  | 10-027 | 10-064 | 11-003 | 11-051 |  | APP |  |  | 0 | 174599 | 17459900 | 100 |  |  |  |  |  |  |  |  | 3113A | 10-018 |  |  |  |
| 131135015D |  | Vend Fab End Cans - Material Receipt for End Can sets 4-6 | 167d | 2010-01-04 A | 2010-08-30 A | 131135015C FS-83d | 100% |  |  | PROCUREMENT>$50K 69 NO ESCALATION | 158,211 |  | 0 | 158211 | HOGAN J | 1 | 1 | P | JOHN H |  | 10-027 | 10-064 | 11-003 | 11-051 |  | APP |  |  | 0 | 158211 | 15821100 | 100 |  |  |  |  |  |  |  |  | 3113A | 10-018 |  |  |  |
| 131135015F |  | Vend Fab End Cans - Material P.O. for End Can sets 7-8 | 229d | 2010-01-04 A | 2010-11-29 A | 131135015D FS-168d | 100% |  |  | PROCUREMENT>$50K 69 NO ESCALATION | 158,211 |  | 0 | 158211 | HOGAN J | 1 | 1 | P | JOHN H |  | 10-027 | 10-064 | 11-003 | 11-051 |  | APP |  |  | 0 | 158211 | 15821100 | 100 |  |  |  |  |  |  |  |  | 3113A | 10-018 |  |  |  |
| 131135015G |  | Vend Fab End Cans - Material Receipt for End Can sets 9-10 | 242d | 2010-01-04 A | 2010-12-16 A | 131135015F FS-210d | 100% |  |  | PROCUREMENT>$50K 69 NO ESCALATION | 158,211 |  | 0 | 158211 | HOGAN J | 1 | 1 | P | JOHN H |  | 10-027 | 10-064 | 11-003 | 11-051 |  | APP |  |  | 0 | 158211 | 15821100 | 100 |  |  |  |  |  |  |  |  | 3113A | 10-018 |  |  |  |
| 131135015H |  | Vend Fab End Cans - Delivery of Set #1 | 167d | 2010-01-04 A | 2010-08-30 A | 131135015G FS-247d | 100% |  |  | PROCUREMENT>$50K 69 NO ESCALATION | 136,921 |  | 0 | 136921 | HOGAN J | 1 | 1 | P | JOHN H |  | 10-027 | 10-064 | 11-003 | 11-051 |  | APP |  |  | 0 | 136921 | 13692100 | 100 |  |  |  |  |  |  |  |  | 3113A | 10-018 |  |  |  |
| 131135015J |  | Vend Fab End Cans - Delivery of Set #2 | 206d | 2010-01-04 A | 2010-10-25 A | 131135015H FS-146d | 100% |  |  | PROCUREMENT>$50K 69 NO ESCALATION | 55,456 |  | 0 | 55456 | HOGAN J | 1 | 1 | P | JOHN H |  | 10-027 | 10-064 | 11-003 | 11-051 |  | APP |  |  | 0 | 55456 | 5545600 | 100 |  |  |  | 11-012 |  |  |  |  | 3113A | 10-018 |  |  |  |
| 131135015K |  | Vend Fab End Cans - Delivery of Set #3 | 206d | 2010-01-04 A | 2010-10-25 A | 131135015J FS-189d | 100% |  |  | PROCUREMENT>$50K 69 NO ESCALATION | 55,456 |  | 0 | 55456 | HOGAN J | 1 | 1 | P | JOHN H |  | 10-027 | 10-064 | 11-003 | 11-051 | 12-018F | APP |  |  | 0 | 55456 | 5545600 | 100 |  |  |  | 11-012 | 12-028F |  |  |  | 3113A | 10-018 |  |  |  |
| 131135015N |  | Vend Fab End Cans - Delivery of Set #4 | 245d | 2010-01-04 A | 2010-12-23 A | 131135015K FS-189d | 100% | 2010-01-04 | 2010-12-21 | PROCUREMENT>$50K 69 NO ESCALATION | 55,456 |  | 0 | 55456 | HOGAN J | 1 | 1 | P | JOHN H |  | 10-027 | 10-064 |  | 11-051 | 12-018F | APP |  |  | 0 | 55456 | 5545600 | 100 |  |  | 10-066 | 11-012 | 12-028F |  |  |  | 3113A | 10-018 |  |  |  |
| 131135015O |  | Vend Fab End Cans - Delivery of Set #5 | 277d | 2010-01-04 A | 2011-02-14 A | 131135015N FS-230d | 100% |  |  | PROCUREMENT>$50K 69 NO ESCALATION | 55,456 |  | 0 | 55456 | HOGAN J | 1 | 1 | P | JOHN H |  | 10-027 | 10-064 |  | 11-051 | 12-018F | APP |  |  | 0 | 55456 | 5545600 | 100 |  |  | 10-066 | 11-012 | 12-028F |  |  |  | 3113A | 10-018 |  |  |  |
| 131135015P |  | Vend Fab End Cans - Delivery of Set #6 | 281d | 2010-01-04 A | 2011-02-21 A | 131135015O FS-230d | 100% | 2010-01-04 | 2011-02-18 | PROCUREMENT>$50K 69 NO ESCALATION | 55,456 |  | 0 | 55456 | HOGAN J | 1 | 1 | P | JOHN H |  | 10-027 | 10-064 |  | 11-051 | 12-018F | APP |  |  | 0 | 55456 | 5545600 | 100 |  |  | 10-066 | 11-012 |  |  |  |  | 3113A | 10-018 |  |  |  |
| 131135015Q |  | Vend Fab End Cans - Delivery of Set #7 | 305d | 2010-01-04 A | 2011-03-25 A | 131135015P FS-247d | 100% |  |  | PROCUREMENT>$50K 69 NO ESCALATION | 55,456 |  | 0 | 55456 | HOGAN J | 1 | 1 | P | JOHN H |  | 10-027 | 10-064 |  | 11-051 | 12-018F | APP |  |  | 0 | 55456 | 5545600 | 100 |  |  | 10-066 |  | 12-028F |  |  |  | 3113A | 10-018 |  |  |  |
| 131135015R |  | Vend Fab End Cans - Delivery of Set #8 | 346d | 2010-01-04 A | 2011-05-23 A | 131135015Q FS-267d | 100% |  |  | PROCUREMENT>$50K 69 NO ESCALATION | 55,456 |  | 0 | 55456 | HOGAN J | 1 | 1 | P | JOHN H |  | 10-027 | 10-064 |  | 11-051 | 12-018F | APP |  |  | 0 | 55456 | 5545600 | 100 |  |  | 10-066 |  | 12-028F |  |  |  | 3113A | 10-018 |  |  |  |
| 131135015S |  | Vend Fab End Cans - Delivery of Set #9 | 383d | 2010-01-04 A | 2011-07-15 A | 131135015R FS-267d | 100% |  |  | PROCUREMENT>$50K 69 NO ESCALATION | 55,456 |  | 0 | 55456 | HOGAN J | 1 | 1 | P | JOHN H |  | 10-027 | 10-064 |  | 11-051 | 12-018F | APP |  |  | 0 | 55456 | 5545600 | 100 |  |  | 10-066 |  | 12-028F |  |  |  | 3113A | 10-018 |  |  |  |
| 131135015T |  | Vend Fab End Cans - Delivery of Set #10 | 390d | 2010-01-04 A | 2011-07-26 A | 131135015S FS-309d | 100% |  |  | PROCUREMENT>$50K 69 NO ESCALATION | 55,456 |  | 0 | 55456 | HOGAN J | 1 | 1 | P | JOHN H |  | 10-027 | 10-064 |  | 11-051 | 12-018F | APP |  |  | 0 | 55456 | 5545600 | 100 |  |  | 10-066 |  | 12-028F |  |  |  | 3113A | 10-018 |  |  |  |
| 131135015 |  | Technical Oversight End Cans Procurement FY10 | 170d | 2010-02-01 A | 2010-09-30 A | 131135010 FS-21d | 100% |  |  | MECH ENG [45.82 h]; TRAVEL; MECH DES [45.82 h]; SUPPLIES & MATERIALS | 20,822.76 | 5,090.15 | 0 | 20822.7538 | HOGAN J | 1 | 1 | E | JOHN H | 08-050 | 10-027 | 10-064 |  | 11-051 | 12-018F | APP |  |  |  |  |  |  | 09-017 |  | 10-066 |  | 12-028F | 100 | 100 |  | 3113A | 10-018 |  |  |  |
| 131135016 |  | Electronic Valve Actuators | 11d | 2010-07-02 A | 2010-07-19 A | 131135010 FS+104d | 100% |  |  | PROCUREMENT<$50K 60 | 25,000 |  | 0 | 25000 | HOGAN J | 1 | 1 | D | JOHN H |  |  | 10-064 |  | 11-051 | 12-018F |  |  |  | 0 | 25000 | 2500000 | 100 |  |  | 10-066 |  | 12-028F |  |  |  |  |  |  |  |  |
| 131135017 |  | Additional End Can Hardware | 11d | 2010-07-02 A | 2010-07-19 A | 131135010 FS+104d | 100% |  |  | PROCUREMENT>$50K 69 NO ESCALATION | 25,000 |  | 0 | 25000 | HOGAN J | 1 | 1 | D | JOHN H |  |  | 10-064 |  | 11-051 | 12-018F | APP |  |  | 0 | 25000 | 2500000 | 100 |  |  | 10-066 |  | 12-028F |  |  |  | 3113A |  |  |  |  |
| 131135020 |  | Receive & Insp End Cans Set #1 FY10 | 18d | 2010-08-31 A | 2010-09-24 A | 131135015H | 100% |  |  | SUPPLIES & MATERIALS; MECH DES [5.73 h]; MECH ENG [14.33 h]; MECH TECH [57.33 h] | 4,068.29 | 3,595.81 | 0 | 4068.2899 | HOGAN J | 1 | 1 | H | JOHN H | 08-050 | 10-027 | 10-064 | 11-003 | 11-051 | 12-018F |  |  |  |  |  |  |  | 09-017 |  |  |  |  |  |  |  |  | 10-018 | 11-001 |  |  |
| 131135020a |  | Receive & Insp End Cans Set #1 FY11 | 18d | 2010-08-31 A | 2010-09-24 A | 131135020 | 100% |  |  | SUPPLIES & MATERIALS; MECH DES [2.27 h]; MECH ENG [5.67 h]; MECH TECH [22.67 h] | 1,615.06 | 1,422.31 | 0 | 1660.387 | HOGAN J | 1 | 1 | H | JOHN H | 08-050 | 10-027 | 10-064 | 11-003 | 11-051 | 12-018F |  |  |  |  |  |  |  | 09-017 |  |  |  |  |  |  |  |  | 10-018 | 11-001 |  |  |
| 131135015A |  | Technical Oversight End Cans Procurement FY11 | 141d | 2010-10-01 A | 2011-04-29 A | 131135015 | 100% |  |  | SUPPLIES & MATERIALS; TRAVEL; MECH DES [34.18 h]; MECH ENG [120 h] | 21,860.96 | 9,749.52 | 0 | 21860.9624 | HOGAN J | 1 | 1 | E | JOHN H |  | 10-027 | 10-064 |  | 11-051 | 12-018F | APP |  |  |  |  |  |  |  |  | 10-066 |  | 12-028F | 100 | 100 |  | 3113A | 10-018 |  | 148936.1702 | -148836.1702 |
| 131135025 |  | Receive & Insp End Cans Set #2 | 7d | 2010-10-18 A | 2010-10-26 A | 131135015J | 100% |  |  | MECH TECH [80 h]; MECH DES [8 h]; MECH ENG [20 h]; SUPPLIES & MATERIALS | 5,858.34 | 5,178.04 | 0 | 5858.34 | HOGAN J | 1 | 1 | H | JOHN H | 08-050 | 10-027 | 10-064 | 11-003 | 11-051 |  |  |  |  |  |  |  |  | 09-017 |  |  | 11-012 |  |  |  |  |  | 10-018 |  |  |  |
| 131135030 |  | Receive & Insp End Cans Set #3 | 19d | 2010-11-01 A | 2010-11-29 A | 131135015K | 100% |  |  | MECH DES [8 h]; MECH ENG [20 h]; SUPPLIES & MATERIALS; MECH TECH [80 h] | 5,858.34 | 5,178.04 | 0 | 5858.34 | HOGAN J | 1 | 1 | H | JOHN H | 08-050 | 10-027 | 10-064 | 11-003 | 11-051 | 12-018F |  |  |  |  |  |  |  | 09-017 |  |  | 11-012 | 12-028F |  |  |  |  | 10-018 |  |  |  |
| 131135035 |  | Receive & Insp End Cans Set #4 | 31d | 2010-12-01 A | 2011-01-21 A | 131135015N | 100% |  |  | MECH TECH [80 h]; MECH DES [8 h]; MECH ENG [20 h]; SUPPLIES & MATERIALS | 5,858.34 | 5,178.04 | 0 | 5858.34 | HOGAN J | 1 | 1 | H | JOHN H |  | 10-027 | 10-064 |  | 11-051 | 12-018F |  |  |  |  |  |  |  |  |  | 10-066 | 11-012 | 12-028F |  |  |  |  | 10-018 |  |  |  |
| 131135040 |  | Receive & Insp End Cans Set #5 | 39d | 2011-02-01 A | 2011-03-28 A | 131135015O | 100% |  |  | SUPPLIES & MATERIALS; MECH TECH [80 h]; MECH DES [8 h]; MECH ENG [20 h] | 5,858.34 | 5,178.04 | 0 | 5858.34 | HOGAN J | 1 | 1 | H | JOHN H |  | 10-027 | 10-064 |  | 11-051 | 12-018F |  |  |  |  |  |  |  |  |  | 10-066 | 11-012 | 12-028F |  |  |  |  | 10-018 |  |  |  |
| 131135045 |  | Receive & Insp End Cans Set #6 | 39d | 2011-02-01 A | 2011-03-28 A | 131135015P | 100% |  |  | SUPPLIES & MATERIALS; MECH TECH [80 h]; MECH DES [8 h]; MECH ENG [20 h] | 5,858.34 | 5,178.04 | 0 | 5858.34 | HOGAN J | 1 | 1 | H | JOHN H |  | 10-027 | 10-064 |  | 11-051 | 12-018F |  |  |  |  |  |  |  |  |  | 10-066 | 11-012 |  |  |  |  |  | 10-018 |  |  |  |
| 131135050 |  | Receive & Insp End Cans Set #7 | 25d | 2011-03-22 A | 2011-04-25 A | 131135015Q | 100% |  |  | SUPPLIES & MATERIALS; MECH TECH [80 h]; MECH DES [8 h]; MECH ENG [20 h] | 5,858.34 | 5,178.04 | 0 | 5858.34 | HOGAN J | 1 | 1 | H | JOHN H |  | 10-027 | 10-064 |  | 11-051 | 12-018F |  |  |  |  |  |  |  |  |  | 10-066 |  | 12-028F |  |  |  |  | 10-018 |  |  |  |
| 131135055 |  | Receive & Insp End Cans Set #8 | 48d | 2011-05-16 A | 2011-07-23 A | 131135015R | 100% | 2011-05-16 | 2011-07-22 | MECH DES [8 h]; MECH ENG [20 h]; SUPPLIES & MATERIALS; MECH TECH [80 h] | 5,858.34 | 5,178.04 | 0 | 5858.34 | HOGAN J | 1 | 1 | H | JOHN H |  | 10-027 | 10-064 |  | 11-051 | 12-018F |  |  |  |  |  |  |  |  |  | 10-066 |  | 12-028F |  |  |  |  | 10-018 |  |  |  |
| 131135060 |  | Receive & Insp End Cans Set #9 | 37d | 2011-07-01 A | 2011-08-23 A | 131135015S | 100% |  |  | MECH TECH [80 h]; MECH DES [8 h]; MECH ENG [20 h]; SUPPLIES & MATERIALS | 5,858.34 | 5,178.04 | 0 | 5858.34 | HOGAN J | 1 | 1 | H | JOHN H |  | 10-027 | 10-064 |  | 11-051 | 12-018F |  |  |  |  |  |  |  |  |  | 10-066 |  | 12-028F |  |  |  |  | 10-018 |  |  |  |
| 131135065 |  | Receive & Insp End Cans Set #10 | 31d | 2011-07-18 A | 2011-08-29 A | 131135015T, 131135016, 131135017, 131135015A FS-60d | 100% |  |  | MECH TECH [80 h]; MECH DES [8 h]; MECH ENG [20 h]; SUPPLIES & MATERIALS | 5,858.34 | 5,178.04 | 0 | 5858.34 | HOGAN J | 1 | 1 | H | JOHN H |  | 10-027 | 10-064 |  | 11-051 | 12-018F |  |  |  |  |  |  |  |  |  | 10-066 |  | 12-028F |  |  |  |  | 10-018 |  |  |  |
| 131135070 |  | Re-Baseline Actuals Adjustment | 1d | 2013-08-30 A | 2013-08-30 A |  | 100% | 2013-09-03 | 2013-09-03 | PROCUREMENT>$50K 69 NO ESCALATION | -11,415.67 |  |  |  |  |  |  |  |  |  |  |  |  |  |  |  |  |  |  |  |  | 100 |  |  |  |  |  |  |  | ADJ |  |  |  |  |  |

| ID | WBS | Activity | Duration | Start | Finish | Predecessors | Complete | Planned start | Planned finish | Resources | Cost | Actual cost | Calculated Remaining Total Cost | MONTHLY EV COST | RESP - Responsibility | STRT%COMP for CM EVM | FNSH%COMP for CM EVM | EVMS Reporting Codes | CAM RESPONSIBLE | CR 08-050 | Remaining Material Cost Based on % Compl | Claimed Material Cost Based on % Complet | Initial Claimed Material Calc | Claimed Material Divider | Advance Purchase Plan > 500K | 12 GEV MAJOR PROCUREMENT CATAGORY | CR 09-017 | CR 10-004 | CR 10-027 | CR 10-064 | CR 11-003 | CR 11-012 | CR 11-051 | CR 12-018 | CR 12-028 | CR 10-066 | LOE Divider | LOE Multiplier | CR 11-001 | ReBaseline Actuals Adjustment |
| --- | --- | --- | --- | --- | --- | --- | --- | --- | --- | --- | --- | --- | --- | --- | --- | --- | --- | --- | --- | --- | --- | --- | --- | --- | --- | --- | --- | --- | --- | --- | --- | --- | --- | --- | --- | --- | --- | --- | --- | --- |
|  | 6 | **1.3.1.1.3.6 VACUUM VESSELS** |  | 2009-02-02 | 2013-08-30 |  |  |  |  |  |  |  |  |  |  |  |  |  |  |  |  |  |  |  |  |  |  |  |  |  |  |  |  |  |  |  |  |  |  |  |
| 131136010 |  | Proc Vac Vessels | 197d | 2009-02-02 A | 2009-11-09 A | 9-100M FS-500d | 100% |  |  | MECH ENG [20 h]; MECH DES [20 h] | 2,162.78 | 2,162.78 | 0 | 2221.8 | HOGAN J | 1 | 1 | H | JOHN H | 08-050 |  |  |  |  |  |  |  |  |  |  |  |  |  |  |  |  |  |  |  |  |
| 131136016 |  | Vend Fab - Vac Vessels Peg Point #1 Materials | 40d | 2009-11-25 A | 2010-02-01 A | 9-100M FS+39d | 100% |  |  | PROCUREMENT>$50K 69; PROCUREMENT<$50K 60 NO ESCALATION | 184,500 |  | 0 | 184500 | HOGAN J | 1 | 1 | P | JOHN H | 08-050 | 0 | 184500 | 18450000 | 100 | APP | 3113B | 09-017 | 10-004 | 10-027 | 10-064 | 11-003 | 11-012 | 11-051 |  |  |  |  |  |  |  |
| 131136016a |  | Vend Fab - Vac Vessels Peg Point #2 Acceptance of First Article | 99d | 2009-11-25 A | 2010-04-26 A | 131136016 FS-39d | 100% |  |  | PROCUREMENT>$50K 69 NO ESCALATION | 61,812 |  | 0 | 61812 | HOGAN J | 1 | 1 | P | JOHN H |  | 0 | 61812 | 6181200 | 100 | APP | 3113B |  | 10-004 | 10-027 | 10-064 | 11-003 | 11-012 | 11-051 |  |  |  |  |  |  |  |
| 131136016b |  | Vend Fab - Vac Vessels Peg Point #4 Completion of Production components prior to Welding | 99d | 2009-11-25 A | 2010-04-26 A | 131136016a FS-103d | 100% |  |  | PROCUREMENT>$50K 69 NO ESCALATION | 162,925 |  | 0 | 162925 | HOGAN J | 1 | 1 | P | JOHN H |  | 0 | 162925 | 16292500 | 100 | APP | 3113B |  | 10-004 | 10-027 | 10-064 | 11-003 | 11-012 | 11-051 |  |  |  |  |  |  |  |
| 131136016c |  | Vend Fab - Vac Vessels Peg Point #3 First Article Shipped | 145d | 2009-11-25 A | 2010-06-30 A | 131136016b FS-103d | 100% |  |  | PROCUREMENT>$50K 69 NO ESCALATION | 15,528 |  | 0 | 15528 | HOGAN J | 1 | 1 | P | JOHN H |  | 0 | 15528 | 1552800 | 100 | APP | 3113B |  | 10-004 | 10-027 | 10-064 | 11-003 | 11-012 | 11-051 |  |  |  |  |  |  |  |
| 131136016d |  | Vend Fab - Vac Vessels Peg Point #5 Vacuum Vessel Assembly #2 Shipped | 226d | 2009-11-25 A | 2010-10-25 A | 131136016c FS-145d | 100% |  |  | PROCUREMENT>$50K 69 NO ESCALATION | 42,313 |  | 0 | 42313 | HOGAN J | 1 | 1 | P | JOHN H |  | 0 | 42313 | 4231300 | 100 | APP | 3113B |  | 10-004 | 10-027 | 10-064 | 11-003 | 11-012 | 11-051 |  |  |  |  |  |  |  |
| 131136016f |  | Vend Fab - Vac Vessels Peg Point #6 Vacuum Vessel Assembly #3 Shipped | 249d | 2009-11-25 A | 2010-11-29 A | 131136016d FS-188d | 100% |  |  | PROCUREMENT>$50K 69 NO ESCALATION | 42,313 |  | 0 | 42313 | HOGAN J | 1 | 1 | P | JOHN H |  | 0 | 42313 | 4231300 | 100 | APP | 3113B |  | 10-004 | 10-027 | 10-064 | 11-003 | 11-012 | 11-051 | 12-018F | 12-028F |  |  |  |  |  |
| 131136016g |  | Vend Fab - Vac Vessels Peg Point #7 Vacuum Vessel Assembly #4 Shipped | 273d | 2009-11-25 A | 2011-01-10 A | 131136016f FS-209d | 100% |  |  | PROCUREMENT>$50K 69 NO ESCALATION | 42,313 |  | 0 | 42313 | HOGAN J | 1 | 1 | P | JOHN H |  | 0 | 42313 | 4231300 | 100 | APP | 3113B |  | 10-004 | 10-027 | 10-064 |  | 11-012 | 11-051 | 12-018F | 12-028F | 10-066 |  |  |  |  |
| 131136016h |  | Vend Fab - Vac Vessels Peg Point #8 Vacuum Vessel Assembly #5 Shipped | 306d | 2009-11-25 A | 2011-02-28 A | 131136016g FS-230d | 100% |  |  | PROCUREMENT>$50K 69 NO ESCALATION | 42,313 |  | 0 | 42313 | HOGAN J | 1 | 1 | P | JOHN H |  | 0 | 42313 | 4231300 | 100 | APP | 3113B |  | 10-004 | 10-027 | 10-064 |  | 11-012 | 11-051 | 12-018F | 12-028F | 10-066 |  |  |  |  |
| 131136016j |  | Vend Fab - Vac Vessels Peg Point #9 Vacuum Vessel Assembly #6 Shipped | 326d | 2009-11-25 A | 2011-03-28 A | 131136016h FS-250d | 100% |  |  | PROCUREMENT>$50K 69 NO ESCALATION | 42,313 |  | 0 | 42313 | HOGAN J | 1 | 1 | P | JOHN H |  | 0 | 42313 | 4231300 | 100 | APP | 3113B |  | 10-004 | 10-027 | 10-064 |  | 11-012 | 11-051 | 12-018F |  | 10-066 |  |  |  |  |
| 131136016k |  | Vend Fab - Vac Vessels Peg Point #10 Vacuum Vessel Assembly #7 Shipped | 488d | 2009-11-25 A | 2011-11-14 A | 131136016j FS-287d | 100% |  |  | PROCUREMENT>$50K 69 NO ESCALATION | 42,313 |  | 0 | 42313 | HOGAN J | 1 | 1 | P | JOHN H |  | 0 | 42313 | 4231300 | 100 | APP | 3113B |  | 10-004 | 10-027 | 10-064 |  |  | 11-051 | 12-018F | 12-028F | 10-066 |  |  |  |  |
| 131136016n |  | Vend Fab - Vac Vessels Peg Point #11 Vacuum Vessel Assembly #8 Shipped | 520d | 2009-11-25 A | 2012-01-09 A | 131136016k FS-306d | 100% |  |  | PROCUREMENT>$50K 69 NO ESCALATION | 42,313 |  | 0 | 42313 | HOGAN J | 1 | 1 | P | JOHN H |  | 0 | 42313 | 4231300 | 100 | APP | 3113B |  | 10-004 | 10-027 | 10-064 |  |  | 11-051 | 12-018F | 12-028F | 10-066 |  |  |  |  |
| 131136016o |  | Vend Fab - Vac Vessels Peg Point #12 Vacuum Vessel Assembly #9 Shipped | 524d | 2009-11-25 A | 2012-01-16 A | 131136016n FS-329d | 100% | 2009-11-25 | 2012-01-13 | PROCUREMENT>$50K 69 NO ESCALATION | 42,313 |  | 0 | 42313 | HOGAN J | 1 | 1 | P | JOHN H |  | 0 | 42313 | 4231300 | 100 | APP | 3113B |  | 10-004 | 10-027 | 10-064 |  |  | 11-051 | 12-018F | 12-028F | 10-066 |  |  |  |  |
| 131136016p |  | Vend Fab - Vac Vessels Peg Point #13 Vacuum Vessel Assembly #10 Shipped | 529d | 2009-11-25 A | 2012-01-23 A | 131136016o FS-350d | 100% |  |  | PROCUREMENT>$50K 69 NO ESCALATION | 42,313 |  | 0 | 42313 | HOGAN J | 1 | 1 | P | JOHN H |  | 0 | 42313 | 4231300 | 100 | APP | 3113B |  | 10-004 | 10-027 | 10-064 |  |  | 11-051 | 12-018F | 12-028F | 10-066 |  |  |  |  |
| 131136015 |  | Vend Fab - Vac Vessels Lot #1 Original Labor FY10 | 145d | 2010-03-08 A | 2010-09-30 A | 9-100M FS+102d | 100% | 2010-03-08 | 2010-09-29 | MECH ENG [77.87 h]; SR STAFF [38.93 h]; MECH DES [77.87 h]; SUPPLIES & MATERIALS; TRAVEL | 39,518.95 | 12,798.5 | 0 | 39518.9499 | HOGAN J | 1 | 1 | E | JOHN H | 08-050 |  |  |  |  | APP | 3113B | 09-017 | 10-004 | 10-027 | 10-064 | 11-003 |  | 11-051 | 12-018F |  |  | 100 | 100 | 11-001 |  |
| 131136020 |  | Receive & Insp Vac Vessels First Article | 43d | 2010-06-30 A | 2010-08-30 A | 131136015a, 131136016c | 100% |  |  | MECH DES [16 h]; MECH ENG [24 h]; MECH TECH [40 h]; SUPPLIES & MATERIALS | 5,020.21 | 3,973.84 | 0 | 5020.21 | HOGAN J | 1 | 1 | H | JOHN H | 08-050 |  |  |  |  |  |  | 09-017 | 10-004 | 10-027 | 10-064 | 11-003 |  | 11-051 | 12-018F |  |  |  |  |  |  |
| 131136017 |  | Vend Fab Insulating Vac Components and Hardware | 213d | 2010-08-09 A | 2011-06-18 A | 131135010 FS+104d | 100% | 2010-08-09 | 2011-06-17 | PROCUREMENT<$50K 60 | 40,000 |  | 0 | 40000 | HOGAN J | 1 | 1 | D | JOHN H |  | 0 | 40000 | 4000000 | 100 |  |  |  |  |  | 10-064 |  |  | 11-051 | 12-018F | 12-028F | 10-066 |  |  |  |  |
| 131136015a |  | Vend Fab - Vac Vessels Lot #1 Original Labor FY11 | 16d | 2010-11-01 A | 2010-11-22 A | 131136015 | 100% |  |  | SR STAFF [1.07 h]; MECH DES [2.13 h]; SUPPLIES & MATERIALS; TRAVEL; MECH ENG [2.13 h] | 1,117.23 | 361.34 | 0 | 1117.2276 | HOGAN J | 1 | 1 | E | JOHN H | 08-050 |  |  |  |  | APP | 3113B | 09-017 | 10-004 | 10-027 | 10-064 | 11-003 |  | 11-051 | 12-018F |  |  | 100 | 100 | 11-001 |  |
| 131136025 |  | Receive & Insp Vac Vessel Assembly #2 | 9d | 2010-11-15 A | 2010-11-29 A | 131136020, 131136016d | 100% |  |  | MECH TECH [40 h]; MECH DES [16 h]; MECH ENG [16 h]; SUPPLIES & MATERIALS | 3,806.88 | 3,556.88 | 0 | 3697.04 | HOGAN J | 1 | 1 | H | JOHN H | 08-050 |  |  |  |  |  |  | 09-017 | 10-004 | 10-027 | 10-064 | 11-003 | 11-012 | 11-051 |  |  |  |  |  |  |  |
| 131136030 |  | Receive & Insp Vac Vessels Assembly #3 | 9d | 2010-11-15 A | 2010-11-29 A | 131136016f, 131136025 | 100% |  |  | MECH ENG [8 h]; SUPPLIES & MATERIALS; MECH DES [8 h]; MECH TECH [40 h] | 2,897.82 | 2,639.84 | 0 | 2897.82 | HOGAN J | 1 | 1 | H | JOHN H | 08-050 |  |  |  |  |  |  | 09-017 | 10-004 | 10-027 | 10-064 | 11-003 | 11-012 | 11-051 | 12-018F | 12-028F |  |  |  |  |  |
| 131136035 |  | Receive & Insp Vac Vessels Assembly #4 | 33d | 2011-01-11 A | 2011-02-28 A | 131136030, 131136016g | 100% |  |  | MECH ENG [8 h]; SUPPLIES & MATERIALS; MECH DES [8 h]; MECH TECH [40 h] | 2,897.82 | 2,639.84 | 0 | 2897.82 | HOGAN J | 1 | 1 | H | JOHN H |  |  |  |  |  |  |  |  | 10-004 | 10-027 | 10-064 |  | 11-012 | 11-051 | 12-018F | 12-028F | 10-066 |  |  |  |  |
| 131136040 |  | Receive & Insp Vac Vessels Assembly #5 | 21d | 2011-02-28 A | 2011-03-28 A | 131136035, 131136016h | 100% |  |  | SUPPLIES & MATERIALS; MECH DES [4 h]; MECH TECH [40 h]; MECH ENG [4 h] | 2,439.3 | 2,181.32 | 0 | 2439.3 | HOGAN J | 1 | 1 | H | JOHN H |  |  |  |  |  |  |  |  | 10-004 | 10-027 | 10-064 |  | 11-012 | 11-051 | 12-018F | 12-028F | 10-066 |  |  |  |  |
| 131136045 |  | Receive & Insp Vac Vessels Assembly #6 | 21d | 2011-03-28 A | 2011-04-25 A | 131136016j, 131136040 | 100% |  |  | SUPPLIES & MATERIALS; MECH DES [4 h]; MECH TECH [40 h]; MECH ENG [4 h] | 2,439.3 | 2,181.32 | 0 | 2439.3 | HOGAN J | 1 | 1 | H | JOHN H |  |  |  |  |  |  |  |  | 10-004 | 10-027 | 10-064 |  | 11-012 | 11-051 | 12-018F |  | 10-066 |  |  |  |  |
| 131136050 |  | Receive & Insp Vac Vessels Assembly #7 | 23d | 2011-11-15 A | 2011-12-19 A | 131136045, 131136016k | 100% |  |  | SUPPLIES & MATERIALS; MECH DES [4 h]; MECH TECH [40 h]; MECH ENG [4 h] | 2,508.74 | 2,250.76 | 0 | 2439.3 | HOGAN J | 1 | 1 | H | JOHN H |  |  |  |  |  |  |  |  | 10-004 | 10-027 | 10-064 |  |  | 11-051 | 12-018F | 12-028F | 10-066 |  |  |  |  |
| 131136055 |  | Receive & Insp Vac Vessels Assembly #8 | 5d | 2012-01-09 A | 2012-01-16 A | 131136016n, 131136050 | 100% | 2012-01-09 | 2012-01-13 | MECH ENG [4 h]; SUPPLIES & MATERIALS; MECH DES [4 h]; MECH TECH [40 h] | 2,508.74 | 2,250.76 | 0 | 2439.3 | HOGAN J | 1 | 1 | H | JOHN H |  |  |  |  |  |  |  |  | 10-004 | 10-027 | 10-064 |  |  | 11-051 | 12-018F | 12-028F | 10-066 |  |  |  |  |
| 131136060 |  | Receive & Insp Vac Vessels Assembly #9 | 24d | 2012-01-16 A | 2012-02-20 A | 131136016o, 131136055 | 100% | 2012-01-17 | 2012-02-17 | MECH DES [4 h]; MECH TECH [40 h]; MECH ENG [4 h]; SUPPLIES & MATERIALS | 2,508.74 | 2,250.76 | 0 | 2439.3 | HOGAN J | 1 | 1 | H | JOHN H |  |  |  |  |  |  |  |  | 10-004 | 10-027 | 10-064 |  |  | 11-051 | 12-018F | 12-028F | 10-066 |  |  |  |  |
| 131136065 |  | Receive & Insp Vac Vessels Assembly #10 | 60d | 2012-01-23 A | 2012-04-16 A | 131136017, 131136060 FS-20d, 131136016p | 100% |  |  | MECH ENG [4 h]; SUPPLIES & MATERIALS; MECH DES [4 h]; MECH TECH [40 h] | 2,508.74 | 2,250.76 | 0 | 2439.3 | HOGAN J | 1 | 1 | H | JOHN H |  |  |  |  |  |  |  |  | 10-004 | 10-027 | 10-064 |  |  | 11-051 | 12-018F | 12-028F | 10-066 |  |  |  |  |
| 131136070 |  | Re-Baseline Actuals Adjustment | 1d | 2013-08-30 A | 2013-08-30 A |  | 100% | 2013-09-03 | 2013-09-03 | PROCUREMENT>$50K 69 NO ESCALATION | 29,991.66 |  |  | 29991.66 |  |  |  |  |  |  | 0 | 29991.66 | 2999166 | 100 |  |  |  |  |  |  |  |  |  |  |  |  |  |  |  | ADJ |

| ID | WBS | Activity | Duration | Start | Finish | Predecessors | Complete | Planned start | Planned finish | Resources | Cost | Actual cost | Calculated Remaining Total Cost | MONTHLY EV COST | RESP - Responsibility | STRT%COMP for CM EVM | FNSH%COMP for CM EVM | EVMS Reporting Codes | CAM RESPONSIBLE | CR 08-050 | CR 09-017 | CR 09-042 | CR 10-001 | CR 10-027 | CR 10-064 | CR 11-003 | CR 11-051 | Remaining Material Cost Based on % Compl | Claimed Material Cost Based on % Complet | Initial Claimed Material Calc | Claimed Material Divider | Advance Purchase Plan > 500K | 12 GEV MAJOR PROCUREMENT CATAGORY | LOE Divider | LOE Multiplier | CR 12-018 | Activities with Steps | ReBaseline Actuals Adjustment | CR 10-012 | CR 10-012A | CR 10-066 | CR 12-028 | CR 11-001 | CR 11-012 | LOE % Pre Calc | LOE % |
| --- | --- | --- | --- | --- | --- | --- | --- | --- | --- | --- | --- | --- | --- | --- | --- | --- | --- | --- | --- | --- | --- | --- | --- | --- | --- | --- | --- | --- | --- | --- | --- | --- | --- | --- | --- | --- | --- | --- | --- | --- | --- | --- | --- | --- | --- | --- |
|  | 7 | **1.3.1.1.3.7 BEAM PIPES** |  | 2009-09-25 | 2013-08-30 |  |  |  |  |  |  |  |  |  |  |  |  |  |  |  |  |  |  |  |  |  |  |  |  |  |  |  |  |  |  |  |  |  |  |  |  |  |  |  |  |  |
| 131137010 |  | Proc Beam Pipes Labor FY09 | 77d | 2009-09-25 A | 2010-01-25 A | 9-100M FS-4d | 100% | 2009-09-25 | 2010-01-22 | MECH ENG [0.79 h]; MECH DES [0.63 h] | 80.4 | 80.44 | 0 | 78.0291 | HOGAN J | 1 | 1 | H | JOHN H | 08-050 | 09-017 | 09-042 | 10-001B | 10-027 | 10-064 | 11-003 | 11-051 |  |  |  |  |  |  |  |  |  |  |  |  |  |  |  |  |  |  |  |
| 131137012 |  | Vend Fab - Cold Valves 1-4 | 101d | 2009-09-25 A | 2010-02-26 A | 9-100M FS-4d | 100% |  |  | PROCUREMENT<$50K 60 NO ESCALATION; PROCUREMENT>$50K 69 NO ESCALATION | 79,980 |  | 0 | 79980 | HOGAN J | 1 | 1 | D | JOHN H | 08-050 | 09-017 | 09-042 |  | 10-027 | 10-064 | 11-003 | 11-051 | 0 | 79980 | 7998000 | 100 | APP | 3113C |  |  |  |  |  |  |  |  |  |  |  |  |  |
| 131137013 |  | Vend Fab - Cold Valves 5-8 | 124d | 2009-09-25 A | 2010-03-31 A | 9-100M FS-4d | 100% |  |  | PROCUREMENT>$50K 69 NO ESCALATION; PROCUREMENT<$50K 60 NO ESCALATION | 79,980 |  | 0 | 79980 | HOGAN J | 1 | 1 | D | JOHN H | 08-050 | 09-017 | 09-042 |  | 10-027 | 10-064 | 11-003 | 11-051 | 0 | 79980 | 7998000 | 100 | APP | 3113C |  |  |  |  |  |  |  |  |  |  |  |  |  |
| 131137014 |  | Vend Fab - Cold Valves 9-12 | 124d | 2009-09-25 A | 2010-03-31 A | 9-100M FS-4d | 100% |  |  | PROCUREMENT<$50K 60 NO ESCALATION; PROCUREMENT>$50K 69 NO ESCALATION | 79,980 |  | 0 | 79980 | HOGAN J | 1 | 1 | D | JOHN H | 08-050 | 09-017 | 09-042 |  | 10-027 | 10-064 | 11-003 | 11-051 | 0 | 79980 | 7998000 | 100 | APP | 3113C |  |  |  |  |  |  |  |  |  |  |  |  |  |
| 131137015 |  | Vend Fab - Cold Valves 13-16 | 142d | 2009-09-25 A | 2010-04-26 A | 9-100M FS-4d | 100% |  |  | PROCUREMENT<$50K 60 NO ESCALATION; PROCUREMENT>$50K 69 NO ESCALATION | 79,980 |  | 0 | 79980 | HOGAN J | 1 | 1 | D | JOHN H | 08-050 | 09-017 | 09-042 |  | 10-027 | 10-064 | 11-003 | 11-051 | 0 | 79980 | 7998000 | 100 |  |  |  |  |  |  |  |  |  |  |  |  |  |  |  |
| 131137016 |  | Vend Fab - Cold Valves 17-20 | 142d | 2009-09-25 A | 2010-04-26 A | 9-100M FS-4d | 100% |  |  | PROCUREMENT>$50K 69 NO ESCALATION; PROCUREMENT<$50K 60 NO ESCALATION | 79,980 |  | 0 | 79980 | HOGAN J | 1 | 1 | D | JOHN H |  |  | 09-042 |  | 10-027 | 10-064 | 11-003 | 11-051 | 0 | 79980 | 7998000 | 100 |  |  |  |  |  |  |  |  |  |  |  |  |  |  |  |
| 131137017 |  | Vend Fab - Cold Valves 21-22 | 166d | 2009-09-25 A | 2010-05-28 A | 9-100M FS-4d | 100% |  |  | PROCUREMENT<$50K 60 NO ESCALATION; PROCUREMENT>$50K 69 NO ESCALATION | 39,990 |  | 0 | 39990 | HOGAN J | 1 | 1 | D | JOHN H |  |  | 09-042 |  | 10-027 | 10-064 | 11-003 | 11-051 | 0 | 39990 | 3999000 | 100 |  |  |  |  |  |  |  |  |  |  |  |  |  |  |  |
| 131137010b |  | Proc Beam Pipes Labor FY10 | 74d | 2009-09-30 A | 2010-01-25 A | 131137010 FS-300d | 100% | 2009-09-30 | 2010-01-22 | MECH ENG [19.21 h]; MECH DES [15.37 h] | 1,959.5 | 1,959.72 | 0 | 1960.3173 | HOGAN J | 1 | 1 | H | JOHN H |  |  |  | 10-001B | 10-027 | 10-064 | 11-003 | 11-051 |  |  |  |  |  |  |  |  |  |  |  |  |  |  |  |  |  |  |  |
| 131137011 |  | Vendor Fab Cold Valves - Oversight | 55d | 2009-10-01 A | 2009-12-23 A | 131137010b FS-101d, 9-100M | 100% | 2009-10-01 | 2009-12-18 | SUPPLIES & MATERIALS; MECH DES [10 h]; MECH ENG [10 h] | 5,231.35 | 1,110.9 | 0 | 5231.348933 | HOGAN J | 1 | 1 | E | JOHN H |  |  | 09-042 |  | 10-027 | 10-064 | 11-003 | 11-051 |  |  |  |  |  |  | 100 | 100 |  |  |  |  |  |  |  |  |  |  |  |
| 131137025 |  | Vendor Fab Burst Disc | 18d | 2009-11-02 A | 2009-11-26 A | 9-100M | 100% | 2009-11-02 | 2009-11-25 | MECH DES [10 h]; MECH ENG [10 h]; SUPPLIES & MATERIALS; PROCUREMENT<$50K 60 | 14,021.63 | 1,110.9 | 0 | 14021.630359 | HOGAN J | 1 | 1 | H | JOHN H |  |  | 09-042 |  | 10-027 | 10-064 | 11-003 | 11-051 | 0 | 8790.281426 | 879028.1426 | 100 |  |  |  |  | 12-018F |  |  |  |  |  |  |  |  |  |  |
| 131137030 |  | Receive & Inspect Burst Disc | 18d | 2009-11-23 A | 2009-12-21 A | 131137025 | 100% | 2009-11-23 | 2009-12-18 | MECH ENG [4 h]; MECH DES [3.2 h]; SUPPLIES & MATERIALS; MECH TECH [32 h] | 1,890.36 | 1,743.85 | 0 | 1890.357162 | HOGAN J | 1 | 1 | H | JOHN H |  |  | 09-042 |  | 10-027 | 10-064 | 11-003 | 11-051 |  |  |  |  |  |  |  |  | 12-018F |  |  |  |  |  |  |  |  |  |  |
| 131137020 |  | Receive & Inspect Cold Valves | 74d | 2010-02-16 A | 2010-05-28 A | 131137015 FS-54d, 131137014 FS-32d, 131137013 FS-32d, 131137017 FS-74d, 131137011, 131137016 FS-54d, 131137012 FS-9d | 100% |  |  | MECH ENG [10 h]; MECH DES [8 h]; SUPPLIES & MATERIALS; MECH TECH [80 h] | 5,238.67 | 4,359.62 | 0 | 5238.674972 | HOGAN J | 1 | 1 | S | JOHN H |  |  | 09-042 |  | 10-027 | 10-064 | 11-003 | 11-051 |  |  |  |  |  |  |  |  |  | ST |  |  |  |  |  |  |  |  |  |
| 131137045 |  | Vendor Fab Warm Valves | 40d | 2010-04-05 A | 2010-05-28 A | 9-100M FS+44d | 100% |  |  | MECH DES [10 h]; MECH ENG [10 h]; PROCUREMENT<$50K 60; SUPPLIES & MATERIALS | 49,182.76 | 1,110.9 | 0 | 49182.756063 | HOGAN J | 1 | 1 | D | JOHN H |  |  | 09-042 |  | 10-027 | 10-064 | 11-003 | 11-051 | 0 | 43951.40713 | 4395140.713 | 100 |  |  |  |  | 12-018F |  |  |  |  |  |  |  |  |  |  |
| 131137050 |  | Receive & Inspect Warm Valves | 23d | 2010-05-28 A | 2010-06-30 A | 131137045 FS-111d | 100% |  |  | MECH DES [1.6 h]; SUPPLIES & MATERIALS; MECH TECH [16 h]; MECH ENG [2 h] | 1,750.97 | 871.92 | 0 | 1750.978892 | HOGAN J | 1 | 1 | H | JOHN H |  |  | 09-042 |  | 10-027 | 10-064 | 11-003 | 11-051 |  |  |  |  |  |  |  |  | 12-018F |  |  |  |  |  |  |  |  |  |  |
| 131137034 |  | Vendor Fab Warm to Cold Beam Pipe - Oversight | 259d | 2010-09-01 A | 2011-09-17 A | 9-100M FS+140d | 100% | 2010-09-01 | 2011-09-16 | MECH DES [10 h]; MECH ENG [10 h]; SUPPLIES & MATERIALS | 5,263.88 | 1,143.43 | 0 | 5231.348933 | HOGAN J | 1 | 1 | H | JOHN H |  |  | 09-042 |  | 10-027 | 10-064 | 11-003 | 11-051 |  |  |  |  |  |  |  |  | 12-018F |  |  |  |  |  |  |  |  |  |  |
| 131137035 |  | Vendor Fab Warm to Cold Beam Pipe | 238d | 2010-10-01 A | 2011-09-17 A | 9-100M FS+140d | 100% | 2010-10-01 | 2011-09-16 | PROCUREMENT<$50K 60 NO ESCALATION FY11; PROCUREMENT>$50K 69 NO ESCALATION FY11 | 100,000 |  | 0 | 100000 | HOGAN J | 1 | 1 | D | JOHN H |  |  | 09-042 |  | 10-027 | 10-064 | 11-003 | 11-051 | 0 | 100000 | 10000000 | 100 |  |  |  |  | 12-018F |  |  |  |  |  |  |  |  |  |  |
| 131137040 |  | Receive & Inspect Warm to Cold Beam Pipe | 207d | 2010-12-01 A | 2011-09-30 A | 131137035 FS-103d, 131137034 FS-103d | 100% |  |  | SUPPLIES & MATERIALS; MECH TECH [32 h]; MECH ENG [4 h]; MECH DES [3.2 h] | 2,092.44 | 1,799.42 | 0 | 2036.865838 | HOGAN J | 1 | 1 | H | JOHN H |  |  | 09-042 |  | 10-027 | 10-064 | 11-003 | 11-051 |  |  |  |  |  |  |  |  | 12-018F |  |  |  |  |  |  |  |  |  |  |
| 131137055 |  | Re-Baseline Actuals Adjustment | 1d | 2013-08-30 A | 2013-08-30 A |  | 100% | 2013-09-03 | 2013-09-03 | PROCUREMENT>$50K 69 NO ESCALATION | -43,720.49 |  |  |  |  |  |  |  |  |  |  |  |  |  |  |  |  |  |  |  | 100 |  |  |  |  |  |  | ADJ |  |  |  |  |  |  |  |  |
|  | 8 | **1.3.1.1.3.8 TOP HATS** |  | 2009-07-03 | 2013-08-30 |  |  |  |  |  |  |  |  |  |  |  |  |  |  |  |  |  |  |  |  |  |  |  |  |  |  |  |  |  |  |  |  |  |  |  |  |  |  |  |  |  |
| 131138010 |  | Proc Top Hats Air Side FPC Components | 263d | 2009-07-03 A | 2010-07-26 A | 9-090M FS+150d | 100% | 2009-07-06 | 2010-07-26 | MECH ENG [20 h]; MECH DES [16 h] | 2,025.94 | 2,025.94 | 0 | 1977.64 | HOGAN J | 1 | 1 | H | JOHN H | 08-050 | 09-017 |  |  | 10-027 | 10-064 | 11-003 | 11-051 |  |  |  |  |  |  |  |  | 12-018F |  |  |  |  |  |  |  |  |  |  |
| 131138025 |  | Vendor Fab Vacuum Components Labor Initial | 42d | 2009-12-01 A | 2010-02-05 A | 131138010 FS-200d | 100% |  |  | MECH ENG [26 h]; MECH TECH [26 h]; MECH DES [10.4 h]; SUPPLIES & MATERIALS; ELEC ENG [13.2 h]; TRAVEL | 8,784.97 | 4,142.6 | 0 | 8784.97 | HOGAN J | 1 | 1 | H | JOHN H | 08-050 | 09-017 |  |  | 10-027 | 10-064 | 11-003 | 11-051 |  |  |  |  |  |  |  |  | 12-018F |  |  | 10-012 |  |  |  |  |  |  |  |
| 131138025a5 |  | Vendor Fab Vacuum Components Procurement | 447d | 2009-12-01 A | 2011-09-20 A | 131138010 FS-500d | 100% |  |  | PROCUREMENT>$50K 69 | 786,919.05 |  | 0 | 786919.04597 | HOGAN J | 1 | 1 | D | JOHN H | 08-050 | 09-017 |  |  | 10-027 | 10-064 | 11-003 | 11-051 | 0 | 786919.05 | 78691905 | 100 |  |  |  |  | 12-018F |  |  | 10-012 |  |  |  |  |  |  |  |
| 131138030 |  | Receive & Insp Vacuum Components | 468d | 2010-02-05 A | 2011-12-19 A | 131138025a FS-145d, 131138025a5 FS-145d | 100% |  |  | MECH DES [16 h]; MECH ENG [20 h]; SUPPLIES & MATERIALS; ELEC TECH [40 h]; MECH TECH [120 h] | 10,018.47 | 8,919.68 | 0 | 9806.427758 | HOGAN J | 1 | 1 | H | JOHN H | 08-050 | 09-017 |  |  | 10-027 | 10-064 | 11-003 | 11-051 |  |  |  |  |  |  |  |  | 12-018F |  |  | 10-012 |  |  |  |  |  |  |  |
| 131138025a |  | Vendor Fab Vacuum Components Labor Final | 404d | 2010-02-08 A | 2011-09-19 A | 131138025 | 100% |  |  | MECH TECH [14 h]; MECH DES [5.6 h]; SUPPLIES & MATERIALS; ELEC ENG [7.2 h]; TRAVEL; MECH ENG [14 h] | 4,778.64 | 2,278.91 | 0 | 4736.488 | HOGAN J | 1 | 1 | H | JOHN H | 08-050 | 09-017 |  |  | 10-027 | 10-064 | 11-003 | 11-051 |  |  |  |  |  |  |  |  | 12-018F |  |  | 10-012 |  |  |  |  |  |  |  |
| 131138037 |  | Diagnostic Components Procurement Lots 1 thru 4 | 351d | 2010-04-26 A | 2011-09-20 A | 131138010 FS-40d, 9-100M | 100% |  |  | PROCUREMENT>$50K 69 | 393,459.52 |  | 0 | 393459.51782 | HOGAN J | 1 | 1 | S | JOHN H | 08-050 | 09-017 |  |  | 10-027 | 10-064 | 11-003 | 11-051 | 0 | 393459.52 | 39345952 | 100 |  |  |  |  |  | ST |  |  | 10-012A |  |  |  |  |  |  |
| 131138015c |  | Vend Fab - Warm Windows Lot 1 and 2 | 160d | 2010-05-24 A | 2011-01-18 A | 131138010 FS-500d | 100% |  |  | PROCUREMENT>$50K 69 NO ESCALATION FY10; PROCUREMENT<$50K 60 NO ESCALATION FY10 | 107,824.04 |  | 0 | 107824.04 | HOGAN J | 1 | 1 | D | JOHN H |  |  |  | 10-001B | 10-027 | 10-064 | 11-003 | 11-051 | 0 | 107824.04 | 10782404 | 100 | APP | 3113D |  |  | 12-018F |  |  | 10-012 |  |  |  |  |  |  |  |
| 131138035 |  | Support for Diagnostic Components Procurement | 330d | 2010-05-24 A | 2011-09-19 A | 131138010 FS-70d | 100% |  |  | MECH TECH [20 h]; SUPPLIES & MATERIALS; TRAVEL; MECH ENG [40 h]; MECH DES [40 h]; ELEC ENG [20 h]; ELEC TECH [20 h] | 14,746.41 | 7,604.3 | 0 | 14574.910108 | HOGAN J | 1 | 1 | H | JOHN H | 08-050 | 09-017 |  |  | 10-027 | 10-064 | 11-003 | 11-051 |  |  |  |  |  |  |  |  |  |  |  |  | 10-012A |  |  |  |  |  |  |
| 131138015 |  | Vend Fab - Warm Windows Labor FY09 | 137d | 2010-07-01 A | 2011-01-24 A | 131138010 | 100% |  |  | MECH ENG [25.33 h]; ELEC ENG [5.07 h]; SUPPLIES & MATERIALS; TRAVEL; MECH DES [15.2 h]; MECH TECH [10.13 h] | 5,932.3 | 3,167.33 | 0 | 5783.0499 | HOGAN J | 1 | 1 | H | JOHN H | 08-050 | 09-017 |  | 10-001B | 10-027 | 10-064 | 11-003 | 11-051 |  |  |  |  | APP | 3113D |  |  | 12-018F |  |  |  |  |  |  |  |  |  |  |
| 131138015b |  | Vend Fab - Warm Windows Labor FY10 Initial | 137d | 2010-07-01 A | 2011-01-24 A | 131138015 FS-230d | 100% |  |  | MECH ENG [27.33 h]; ELEC ENG [5.47 h]; SUPPLIES & MATERIALS; TRAVEL; MECH DES [16.4 h]; MECH TECH [10.93 h] | 6,496.01 | 3,417.39 | 0 | 6438.9516 | HOGAN J | 1 | 1 | H | JOHN H |  |  |  | 10-001B | 10-027 | 10-064 | 11-003 | 11-051 |  |  |  |  | APP | 3113D |  |  | 12-018F |  |  | 10-012 |  |  |  |  |  |  |  |
| 131138015ba |  | Vend Fab - Warm Windows Labor FY10 Final | 137d | 2010-07-01 A | 2011-01-24 A | 131138015b FS-230d | 100% |  |  | MECH DES [28.4 h]; MECH TECH [18.94 h]; MECH ENG [47.34 h]; ELEC ENG [9.46 h]; SUPPLIES & MATERIALS; TRAVEL | 11,249.21 | 5,918.45 | 0 | 11150.3848 | HOGAN J | 1 | 1 | H | JOHN H |  |  |  | 10-001B | 10-027 | 10-064 | 11-003 | 11-051 |  |  |  |  | APP | 3113D |  |  | 12-018F |  |  | 10-012 |  |  |  |  |  |  |  |
| 131138060LOE |  | SOTR Oversight FY10 | 64d | 2010-07-01 A | 2010-09-30 A | 9-100M FS+184d | 100% |  |  | MECH ENG [256 h] | 16,857.6 | 16,857.6 | 0 | 16857.6 | HOGAN J | 1 | 1 | E | JOHN H |  |  |  |  |  | 10-064 |  | 11-051 |  |  |  |  |  |  | 100 | 100 | 12-018F |  |  |  |  | 10-066 | 12-028F |  |  |  |  |
| 131138040 |  | Receive & Insp Diagnostic Components Lot 1 | 49d | 2010-07-12 A | 2010-09-17 A | 131138037 FS-110d, 131138035 FS-110d, 131138010 | 100% |  |  | ELEC TECH [20 h]; MECH TECH [20 h]; SUPPLIES & MATERIALS; MECH ENG [20 h]; MECH DES [20 h]; ELEC ENG [20 h] | 8,232.66 | 5,211 | 0 | 8232.661175 | HOGAN J | 1 | 1 | H | JOHN H | 08-050 | 09-017 |  |  | 10-027 | 10-064 | 11-003 | 11-051 |  |  |  |  |  |  |  |  |  |  |  |  | 10-012A |  |  |  |  |  |  |
| 131138015d |  | Vend Fab - Warm Windows Lot 3 and 4 | 397d | 2010-08-02 A | 2012-03-12 A | 9-100M FS+204d | 100% |  |  | PROCUREMENT>$50K 69 NO ESCALATION FY11; PROCUREMENT<$50K 60 NO ESCALATION FY11 | 172,119.34 |  | 0 | 172119.34 | HOGAN J | 1 | 1 | D | JOHN H |  |  |  | 10-001B | 10-027 | 10-064 |  | 11-051 | 0 | 172119.34 | 17211934 | 100 | APP | 3113D |  |  | 12-018F |  |  | 10-012 |  | 10-066 | 12-028F |  |  |  |  |
| 131138015f |  | Vend Fab - Warm Windows Coatings | 397d | 2010-08-02 A | 2012-03-12 A | 9-100M FS+204d | 100% |  |  | PROCUREMENT<$50K 60 NO ESCALATION FY11; PROCUREMENT>$50K 69 NO ESCALATION FY11 | 90,000 |  | 0 | 90000 | HOGAN J | 1 | 1 | D | JOHN H |  |  |  |  |  | 10-064 |  | 11-051 | 0 | 90000 | 9000000 | 100 | APP | 3113D |  |  | 12-018F |  |  | 10-012 |  | 10-066 | 12-028F |  |  |  |  |
| 131138020 |  | Receive & Insp Warm Windows Lot 1 | 55d | 2010-08-09 A | 2010-10-25 A | 131138015c FS-80d, 131138015ba FS-250d | 100% |  |  | MECH DES [10 h]; MECH ENG [20 h]; MECH TECH [30 h]; SUPPLIES & MATERIALS; ELEC ENG [10 h]; ELEC TECH [10 h] | 4,413.86 | 4,139.16 | 0 | 4373.5 | HOGAN J | 1 | 1 | U | JOHN H | 08-050 | 09-017 |  |  | 10-027 | 10-064 | 11-003 | 11-051 |  |  |  |  |  |  |  |  | 12-018F |  |  | 10-012 |  |  |  |  |  |  |  |
| 131138045 |  | Receive & Insp Diagnostic Components Lot 2 FY10 | 99d | 2010-08-23 A | 2011-01-20 A | 131138040 FS-50d | 100% |  |  | SUPPLIES & MATERIALS; ELEC ENG [16 h]; ELEC TECH [16 h]; MECH TECH [16 h]; MECH DES [16 h]; MECH ENG [16 h] | 6,681.37 | 4,264.04 | 0 | 6586.13 | HOGAN J | 1 | 1 | H | JOHN H |  |  |  |  |  | 10-064 | 11-003 | 11-051 |  |  |  |  |  |  |  |  | 12-018F |  |  |  |  |  | 12-028F | 11-001 | 11-012 |  |  |
| 131138045a |  | Receive & Insp Diagnostic Components Lot 2 FY11 | 99d | 2010-08-23 A | 2011-01-20 A | 131138045 FS-70d | 100% |  |  | SUPPLIES & MATERIALS; ELEC ENG [4 h]; ELEC TECH [4 h]; MECH TECH [4 h]; MECH DES [4 h]; MECH ENG [4 h] | 1,689.62 | 1,066.01 | 0 | 1699.01 | HOGAN J | 1 | 1 | H | JOHN H |  |  |  |  |  | 10-064 | 11-003 | 11-051 |  |  |  |  |  |  |  |  | 12-018F |  |  |  |  |  | 12-028F | 11-001 | 11-012 |  |  |
| 131138020b |  | Receive & Insp Warm Windows Lot 2 FY10 | 96d | 2010-09-02 A | 2011-01-27 A | 131138020 FS-45d, 131138015c FS-75d, 131138020a FS-45d | 100% |  |  | MECH ENG [14.22 h]; MECH TECH [21.33 h]; ELEC ENG [7.11 h]; ELEC TECH [7.11 h]; MECH DES [7.11 h]; SUPPLIES & MATERIALS | 3,183.1 | 2,987.76 | 0 | 3109.5868 | HOGAN J | 1 | 1 | U | JOHN H | 08-050 | 09-017 |  |  | 10-027 | 10-064 |  | 11-051 |  |  |  |  |  |  |  |  | 12-018F |  |  | 10-012 |  | 10-066 | 12-028F | 11-001 | 11-012 |  |  |
| 131138020ba |  | Receive & Insp Warm Windows Lot 2 FY11 | 96d | 2010-09-02 A | 2011-01-27 A | 131138020b FS-75d | 100% |  |  | SUPPLIES & MATERIALS; ELEC ENG [2.89 h]; MECH DES [2.89 h]; ELEC TECH [2.89 h]; MECH ENG [5.78 h]; MECH TECH [8.67 h] | 1,296.32 | 1,214.43 | 0 | 1304.1866 | HOGAN J | 1 | 1 | U | JOHN H | 08-050 | 09-017 |  |  | 10-027 | 10-064 |  | 11-051 |  |  |  |  |  |  |  |  | 12-018F |  |  | 10-012 |  | 10-066 | 12-028F | 11-001 | 11-012 |  |  |
| 131138065LOE |  | SOTR Oversight FY11 | 221d | 2010-10-01 A | 2011-08-23 A | 131138060LOE | 100% |  |  | MECH ENG [920 h] | 62,514 | 62,514 | 0 | 62514 | HOGAN J | 1 | 1 | E | JOHN H |  |  |  |  |  | 10-064 |  | 11-051 |  |  |  |  |  |  | 100 | 100 | 12-018F |  |  |  |  | 10-066 | 12-028F |  |  | 7.69230769 | 92.3076923 |
| 131138020a |  | Acceptance Warm Windows Phase 1 | 29d | 2010-10-18 A | 2010-11-29 A | 131138020 FS-1d | 100% |  |  | PROCUREMENT<$50K 60 | 43,129.62 |  | 0 | 43129.62 | HOGAN J | 1 | 1 | U | JOHN H | 08-050 | 09-017 |  |  | 10-027 | 10-064 |  | 11-051 | 0 | 43129.62 | 4312962 | 100 |  |  |  |  | 12-018F |  |  | 10-012 |  | 10-066 | 12-028F |  | 11-012 |  |  |
| 131138020d |  | Receive & Insp Warm Windows Lot 3 | 151d | 2011-03-01 A | 2011-09-30 A | 131138015f FS-178d, 131138015d FS-178d | 100% |  |  | MECH TECH [30 h]; SUPPLIES & MATERIALS; ELEC ENG [10 h]; ELEC TECH [10 h]; MECH DES [10 h]; MECH ENG [20 h] | 4,512.86 | 4,229.4 | 0 | 4512.86 | HOGAN J | 1 | 1 | U | JOHN H | 08-050 | 09-017 |  |  | 10-027 | 10-064 |  | 11-051 |  |  |  |  |  |  |  |  | 12-018F |  |  | 10-012 |  | 10-066 | 12-028F |  |  |  |  |
| 131138020g |  | Receive & Insp Warm Windows Lot 4 | 256d | 2011-03-02 A | 2012-03-12 A | 131138015f FS-90d, 131138015d FS-90d | 100% |  |  | MECH DES [10 h]; MECH ENG [20 h]; MECH TECH [30 h]; SUPPLIES & MATERIALS; ELEC ENG [10 h]; ELEC TECH [10 h] | 4,568.68 | 4,285.22 | 0 | 4512.86 | HOGAN J | 1 | 1 | U | JOHN H | 08-050 | 09-017 |  |  | 10-027 | 10-064 |  | 11-051 |  |  |  |  |  |  |  |  | 12-018F |  |  | 10-012 |  | 10-066 | 12-028F |  |  |  |  |
| 131138050 |  | Receive & Insp Diagnostic Components Lot 3 | 90d | 2011-04-11 A | 2011-08-16 A | 131138045a | 100% |  |  | MECH ENG [20 h]; SUPPLIES & MATERIALS; ELEC ENG [20 h]; ELEC TECH [20 h]; MECH TECH [20 h]; MECH DES [20 h] | 8,495.05 | 5,377 | 0 | 8495.05 | HOGAN J | 1 | 1 | H | JOHN H |  |  |  |  |  | 10-064 |  | 11-051 |  |  |  |  |  |  |  |  | 12-018F |  |  |  |  |  |  |  |  |  |  |
| 131138055 |  | Receive & Insp Diagnostic Components Lot 4 | 147d | 2011-04-20 A | 2011-11-15 A | 131138050 FS-40d | 100% |  |  | MECH ENG [20 h]; SUPPLIES & MATERIALS; ELEC ENG [20 h]; ELEC TECH [20 h]; MECH TECH [20 h]; MECH DES [20 h] | 8,532.36 | 5,414.31 | 0 | 8495.05 | HOGAN J | 1 | 1 | H | JOHN H |  |  |  |  |  | 10-064 |  | 11-051 |  |  |  |  |  |  |  |  | 12-018F |  |  |  |  |  |  |  |  |  |  |
| 131138070 |  | Re-Baseline Actuals Adjustment | 1d | 2013-08-30 A | 2013-08-30 A |  | 100% | 2013-09-03 | 2013-09-03 | PROCUREMENT>$50K 69 NO ESCALATION | 407,552.64 |  |  | 407552.64 |  |  |  |  |  |  |  |  |  |  |  |  |  | 0 | 407552.64 | 40755264 | 100 |  |  |  |  |  |  | ADJ |  |  |  |  |  |  |  |  |

Notes:
- 131137020: Steps: Receive & Inspect Cold Valves 1-4 (done); Receive & Inspect Cold Valves 5-8 (done); Receive & Inspect Cold Valves 9-12 (done); Receive & Inspect Cold Valves 13-16 (done); Receive & Inspect Cold Valves 17-20 (done); Receive & Inspect Cold Valves 21-22 (done)
- 131137050: Steps: Receive & Inspect Warm Valves 1-4; Receive & Inspect Warm Valves 5-8; Receive & Inspect Warm Valves 9-12; Receive & Inspect Warm Valves 13-16; Receive & Inspect Warm Valves 17-20; Receive & Inspect Warm Valves 21-22
- 131138037: Steps: Component Design Complete (done); Component Specification Complete (done); P.O.'s (6) Complete (done); All Componenets Received (done)

| ID | WBS | Activity | Duration | Start | Finish | Predecessors | Complete | Planned start | Planned finish | Resources | Cost | Actual cost | Calculated Remaining Total Cost | MONTHLY EV COST | RESP - Responsibility | STRT%COMP for CM EVM | FNSH%COMP for CM EVM | EVMS Reporting Codes | CAM RESPONSIBLE | CR 08-050 | CR 09-017 | CR 10-027 | CR 10-064 | CR 11-003 | CR 11-051 | CR 12-018 | Remaining Material Cost Based on % Compl | Claimed Material Cost Based on % Complet | Initial Claimed Material Calc | Claimed Material Divider | ReBaseline Actuals Adjustment | Activities with Steps | Installation | CR 11-001 | CR 09-032 | CR 09-032 Repair | CR 11-012 |
| --- | --- | --- | --- | --- | --- | --- | --- | --- | --- | --- | --- | --- | --- | --- | --- | --- | --- | --- | --- | --- | --- | --- | --- | --- | --- | --- | --- | --- | --- | --- | --- | --- | --- | --- | --- | --- | --- |
|  | 9 | **1.3.1.1.3.9 SUPPORTS** |  | 2009-07-01 | 2013-08-30 |  |  |  |  |  |  |  |  |  |  |  |  |  |  |  |  |  |  |  |  |  |  |  |  |  |  |  |  |  |  |  |  |
| 131139010 |  | Proc Supprts | 102d | 2009-07-01 A | 2009-11-23 A | 9-100M FS-500d | 100% |  |  | MECH DES [16 h]; MECH ENG [20 h] | 2,001.19 | 2,001.19 | 0 | 2040.84 | HOGAN J | 1 | 1 | H | JOHN H | 08-050 | 09-017 | 10-027 | 10-064 | 11-003 | 11-051 | 12-018F |  |  |  |  |  |  |  |  |  |  |  |
| 131139015 |  | Vend Fab - Supprts | 81d | 2009-11-23 A | 2010-03-29 A | 131139010 | 100% |  |  | MECH ENG [40 h]; PROCUREMENT<$50K 60; SUPPLIES & MATERIALS; MECH DES [40 h] | 64,876.79 | 4,443.6 | 0 | 64876.792543 | HOGAN J | 1 | 1 | D | JOHN H | 08-050 | 09-017 | 10-027 | 10-064 | 11-003 | 11-051 | 12-018F | 0 | 54939.264072 | 5493926.4072 | 100 |  |  |  |  |  |  |  |
| 131139025 |  | Receive & Insp Supprts | 80d | 2009-11-24 A | 2010-03-29 A | 131139020 FS-80d, 131139015 | 100% |  |  | MECH TECH [40 h]; SUPPLIES & MATERIALS | 2,218.99 | 1,669.6 | 0 | 2218.993879 | HOGAN J | 1 | 1 | U | JOHN H | 08-050 | 09-017 | 10-027 | 10-064 | 11-003 | 11-051 | 12-018F |  |  |  |  |  |  |  |  |  |  |  |
| 131139020 |  | Additional Support Baseplates | 11d | 2010-07-02 A | 2010-07-19 A | 131139010 FS+140d | 100% |  |  | PROCUREMENT>$50K 69 | 70,000 |  | 0 | 70000 | HOGAN J | 1 | 1 | D | JOHN H |  |  |  | 10-064 | 11-003 | 11-051 | 12-018F | 0 | 70000 | 7000000 | 100 |  |  |  |  |  |  |  |
| 131139030 |  | Re-Baseline Actuals Adjustment | 1d | 2013-08-30 A | 2013-08-30 A |  | 100% | 2013-09-03 | 2013-09-03 | PROCUREMENT>$50K 69 NO ESCALATION | -12,504.76 |  |  |  |  |  |  |  |  |  |  |  |  |  |  |  |  |  |  | 100 | ADJ |  |  |  |  |  |  |
|  | 4 | **1.3.1.1.4 INSTALLATION AND ASSEMBLY TOOLING PROCUREMENTS** |  | 2010-02-01 | 2013-08-30 |  |  |  |  |  |  |  |  |  |  |  |  |  |  |  |  |  |  |  |  |  |  |  |  |  |  |  |  |  |  |  |  |
| 13114010 |  | Vend Fab - Installtn & Assy Tooling | 148d | 2010-02-01 A | 2010-08-30 A | 1211020M15, 9-100M | 100% |  |  | SUPPLIES & MATERIALS; PROCUREMENT<$50K 60 | 73,618.62 |  | 0 | 73618.614682 | HOGAN J | 1 | 1 | S | JOHN H | 08-050 |  | 10-027 | 10-064 | 11-003 | 11-051 | 12-018F | 0 | 68124.686211 | 6812468.6211 | 100 |  | ST | Install |  |  |  |  |
| 13114015 |  | Receive & Insp Installtn & Assy Tooling | 139d | 2010-02-15 A | 2010-08-31 A | 13114010 | 100% | 2010-02-16 | 2010-08-31 | MECH ENG [160 h]; SUPPLIES & MATERIALS; MECH DES [320 h] | 27,210.38 | 25,012.8 | 0 | 27210.375516 | HOGAN J | 1 | 1 | H | JOHN H | 08-050 | 09-017 | 10-027 | 10-064 | 11-003 | 11-051 | 12-018F |  |  |  |  |  |  | Install |  |  |  |  |
| 13114012 |  | Vend Fab - Installtn & Assy Tooling Phase 2 | 175d | 2010-07-01 A | 2011-03-18 A | 9-100M FS+184d | 100% |  |  | PROCUREMENT<$50K 60 | 300,000 |  | 0 | 300000 | HOGAN J | 1 | 1 | S | JOHN H |  |  |  | 10-064 | 11-003 | 11-051 | 12-018F | 0 | 300000 | 30000000 | 100 |  | ST |  |  |  |  |  |
| 13114020 |  | Receive & Insp Installtn & Assy Tooling Phase 2 FY10 | 65d | 2010-08-23 A | 2010-11-22 A | 13114012 FS-50d | 100% |  |  | SUPPLIES & MATERIALS; MECH DES [750 h]; MECH ENG [330 h]; MECH TECH [450 h] | 87,043.43 | 75,793.43 | 0 | 85693.5 | HOGAN J | 1 | 1 | S | JOHN H |  |  |  | 10-064 | 11-003 | 11-051 | 12-018F |  |  |  |  |  | ST |  | 11-001 |  |  |  |
| 13114020a |  | Receive & Insp Installtn & Assy Tooling Phase 2 FY11 | 165.37d | 2010-08-23 A | 2011-04-26 A | 13114012 FS-50d | 100% |  |  | SUPPLIES & MATERIALS; MECH DES [1250 h]; MECH ENG [550 h]; MECH TECH [750 h] | 146,703.9 | 127,416.54 | 0 | 147373.13 | HOGAN J | 1 | 1 | S | JOHN H |  |  |  | 10-064 | 11-003 | 11-051 | 12-018F |  |  |  |  |  | ST |  | 11-001 |  |  |  |
| 13114025 |  | Re-Baseline Actuals Adjustment | 1d | 2013-08-30 A | 2013-08-30 A |  | 100% | 2013-09-03 | 2013-09-03 | PROCUREMENT>$50K 69 NO ESCALATION | 229,301.21 |  |  | 229301.21 |  |  |  |  |  |  |  |  |  |  |  |  | 0 | 229301.21 | 22930121 | 100 | ADJ |  |  |  |  |  |  |
|  | 4 | **1.3.1.1.4.4 INSTALLATION AND ASSEMBLY TOOLING** |  |  |  |  |  |  |  |  |  |  |  |  |  |  |  |  |  |  |  |  |  |  |  |  |  |  |  |  |  |  |  |  |  |  |  |
|  | 5 | **1.3.1.1.5 CRYOMODULE TEST INSTRUMENTATION & INTERLOCKS PROCUREMENT** |  | 2010-02-01 | 2010-02-01 |  |  |  |  |  |  |  |  |  |  |  |  |  |  |  |  |  |  |  |  |  |  |  |  |  |  |  |  |  |  |  |  |
| 13115010 |  | Vend Fab - Instrmenttn & Interlocks | 1d | 2010-02-01 A | 2010-02-01 A | 9-100M | 100% |  |  |  |  |  |  | 0 | HOGAN J | 1 | 1 | Z | JOHN H | 08-050 | 09-017 | 10-027 | 10-064 | 11-003 | 11-051 | 12-018F |  |  |  |  |  |  |  |  |  |  |  |
| 13115015 |  | Receive & Insp Instrmenttn & Interlocks | 1d | 2010-02-01 A | 2010-02-01 A | 13115010 | 100% |  |  |  |  |  |  | 0 | HOGAN J | 1 | 1 | Z | JOHN H | 08-050 | 09-017 | 10-027 | 10-064 | 11-003 | 11-051 | 12-018F |  |  |  |  |  |  |  |  |  |  |  |
|  | 5 | **1.3.1.1.5.5 INSTRUMENTATION & INTERLOCKS** |  |  |  |  |  |  |  |  |  |  |  |  |  |  |  |  |  |  |  |  |  |  |  |  |  |  |  |  |  |  |  |  |  |  |  |
|  | 2 | **1.3.1.2 CAVITY STRING ASSEMBLY** |  | 2010-10-25 | 2013-08-30 |  |  |  |  |  |  |  |  |  |  |  |  |  |  |  |  |  |  |  |  |  |  |  |  |  |  |  |  |  |  |  |  |
| 1312000 |  | Re-Baseline Actuals Adjustment | 1d | 2013-08-30 A | 2013-08-30 A |  | 100% | 2013-09-03 | 2013-09-03 | PROCUREMENT>$50K 69 NO ESCALATION | -212,822.09 |  |  |  |  |  |  |  |  |  |  |  |  |  |  |  |  |  |  | 100 | ADJ |  |  |  |  |  |  |
|  | 1 | **1.3.1.2.1 CAVITY PREPARATION** |  | 2010-11-01 | 2012-02-07 |  |  |  |  |  |  |  |  |  |  |  |  |  |  |  |  |  |  |  |  |  |  |  |  |  |  |  |  |  |  |  |  |
|  | 01 | **1.3.1.2.1.01 CAVITY STRING #1 PREPERATION** |  | 2010-11-01 | 2010-12-28 |  |  |  |  |  |  |  |  |  |  |  |  |  |  |  |  |  |  |  |  |  |  |  |  |  |  |  |  |  |  |  |  |
| 1312101005 |  | Cavity String #1 Helium Vessel Welding | 28d | 2010-11-01 A | 2010-12-10 A | 131114070, 131114075, 1311122005, 1311122010 | 100% |  |  | MECH DES [4 h]; MECH ENG [8 h]; MECH TECH [120 h]; SUPPLIES & MATERIALS; ELEC TECH [8 h] | 7,240.88 | 6,240.88 | 0 | 7048.16 | HOGAN J | 1 | 1 | H | JOHN H | 08-050 | 09-017 | 10-027 | 10-064 | 11-003 | 11-051 |  |  |  |  |  |  |  |  |  | 09-032 | 09-032 | 11-012 |
| 1312101030 |  | Cavity #1 VTA Run | 11d | 2010-11-08 A | 2010-11-22 A | 1317000, 1312101005 FS-10d | 100% |  |  | MECH TECH [8 h]; SCIENTIST [8 h]; SR STAFF [8 h]; COMP SCIENT [8 h]; ELEC ENG [8 h]; ELEC TECH [8 h]; MECH DES [8 h]; MECH ENG [8 h] | 4,083.04 | 4,083.04 | 0 | 3956.8 | HOGAN J | 1 | 1 | H | JOHN H | 08-050 | 09-017 | 10-027 | 10-064 | 11-003 | 11-051 |  |  |  |  |  |  |  |  |  | 09-032 | 09-032 | 11-012 |
| 1312101002 |  | Cavity String #1 Cavity Processing | 4d | 2010-12-01 A | 2010-12-06 A | 1311122010 FS+61d, 1311122005 | 100% |  |  | MECH ENG [12.4 h]; MECH TECH [178 h]; SUPPLIES & MATERIALS | 17,589.04 | 8,509.04 | 0 | 17589.04 | HOGAN J | 1 | 1 | H | JOHN H |  |  |  |  | 11-003 | 11-051 | 12-018F |  |  |  |  |  |  |  |  |  |  | 11-012 |
| 1312101035 |  | Cavity #2 VTA Run | 2d | 2010-12-13 A | 2010-12-14 A | 1312101030 FS-2d | 100% |  |  | MECH TECH [8 h]; SCIENTIST [8 h]; SR STAFF [8 h]; COMP SCIENT [8 h]; ELEC ENG [8 h]; ELEC TECH [8 h]; MECH DES [8 h]; MECH ENG [8 h] | 4,083.04 | 4,083.04 | 0 | 3956.8 | HOGAN J | 1 | 1 | H | JOHN H |  |  |  | 10-064 | 11-003 | 11-051 |  |  |  |  |  |  |  |  |  |  |  | 11-012 |
| 1312101040 |  | Cavity #3 VTA Run | 2d | 2010-12-15 A | 2010-12-16 A | 1312101035 FS-2d | 100% |  |  | ELEC TECH [8 h]; MECH DES [8 h]; MECH ENG [8 h]; MECH TECH [8 h]; SCIENTIST [8 h]; SR STAFF [8 h]; COMP SCIENT [8 h]; ELEC ENG [8 h] | 4,083.04 | 4,083.04 | 0 | 3956.8 | HOGAN J | 1 | 1 | H | JOHN H |  |  |  | 10-064 | 11-003 | 11-051 |  |  |  |  |  |  |  |  |  |  |  | 11-012 |
| 1312101045 |  | Cavity #4 VTA Run | 2d | 2010-12-17 A | 2010-12-20 A | 1312101040 FS-2d | 100% |  |  | MECH DES [8 h]; MECH TECH [8 h]; SCIENTIST [8 h]; SR STAFF [8 h]; COMP SCIENT [8 h]; ELEC ENG [8 h]; ELEC TECH [8 h]; MECH ENG [8 h] | 4,083.04 | 4,083.04 | 0 | 3956.8 | HOGAN J | 1 | 1 | H | JOHN H |  |  |  | 10-064 | 11-003 | 11-051 |  |  |  |  |  |  |  |  |  |  |  | 11-012 |
| 1312101050 |  | Cavity #5 VTA Run FY10 | 2d | 2010-12-20 A | 2010-12-21 A | 1312101045 FS-2d | 100% |  |  | SR STAFF [4.8 h]; COMP SCIENT [4.8 h]; ELEC ENG [4.8 h]; ELEC TECH [4.8 h]; MECH DES [4.8 h]; MECH ENG [4.8 h]; MECH TECH [4.8 h]; SCIENTIST [4.8 h] | 2,449.82 | 2,449.82 | 0 | 2374.08 | HOGAN J | 1 | 1 | H | JOHN H |  |  |  | 10-064 | 11-003 | 11-051 |  |  |  |  |  |  |  |  | 11-001 |  |  | 11-012 |
| 1312101050a |  | Cavity #5 VTA Run FY11 | 2d | 2010-12-20 A | 2010-12-21 A | 1312101045 FS-2d, 1312101050 | 100% |  |  | MECH ENG [3.2 h]; MECH TECH [3.2 h]; SCIENTIST [3.2 h]; SR STAFF [3.2 h]; COMP SCIENT [3.2 h]; ELEC ENG [3.2 h]; ELEC TECH [3.2 h]; MECH DES [3.2 h] | 1,633.22 | 1,633.22 | 0 | 1633.216 | HOGAN J | 1 | 1 | H | JOHN H |  |  |  | 10-064 | 11-003 | 11-051 |  |  |  |  |  |  |  |  | 11-001 |  |  | 11-012 |
| 1312101055 |  | Cavity #6 VTA Run | 1d | 2010-12-21 A | 2010-12-22 A | 1312101050 FS-2d, 1312101050a FS-2d | 100% | 2010-12-21 | 2010-12-21 | MECH TECH [8 h]; SCIENTIST [8 h]; SR STAFF [8 h]; COMP SCIENT [8 h]; ELEC ENG [8 h]; ELEC TECH [8 h]; MECH DES [8 h]; MECH ENG [8 h] | 4,083.04 | 4,083.04 | 0 | 4083.04 | HOGAN J | 1 | 1 | H | JOHN H |  |  |  | 10-064 | 11-003 | 11-051 |  |  |  |  |  |  |  |  |  |  |  | 11-012 |
| 1312101060 |  | Cavity #7 VTA Run | 5d | 2010-12-22 A | 2010-12-23 A | 1312101055 FS-2d | 100% | 2010-12-29 | 2011-01-05 | MECH DES [8 h]; MECH ENG [8 h]; MECH TECH [8 h]; SCIENTIST [8 h]; SR STAFF [8 h]; COMP SCIENT [8 h]; ELEC ENG [8 h]; ELEC TECH [8 h] | 4,083.04 | 4,083.04 | 0 | 4083.04 | HOGAN J | 1 | 1 | H | JOHN H |  |  |  | 10-064 | 11-003 | 11-051 |  |  |  |  |  |  |  |  |  |  |  | 11-012 |
| 1312101065 |  | Cavity #8 VTA Run | 5d | 2010-12-27 A | 2010-12-28 A | 1312101060 FS-2d | 100% | 2010-12-29 | 2011-01-05 | MECH TECH [8 h]; COMP SCIENT [8 h]; ELEC ENG [8 h]; ELEC TECH [8 h]; MECH DES [8 h]; MECH ENG [8 h]; SCIENTIST [8 h]; SR STAFF [8 h] | 4,083.04 | 4,083.04 | 0 | 4083.04 | HOGAN J | 1 | 1 | H | JOHN H |  |  |  | 10-064 | 11-003 | 11-051 |  |  |  |  |  |  |  |  |  |  |  | 11-012 |

Notes:
- 13114010: Steps: Q.A. Tooling (done); Cavity String Tooling (done); Cryomodule Assembly Tooling (done); Installation Tolling (done)
- 13114012: Steps: Cavity Handling tooling (done); Q.A. Tooling (done); Cavity String Tooling (done); Cryomodule Assembly Tooling (done); Installation Tooling (done)
- 13114020: Steps: Q.A. Tooling (done); Cavity String Tooling (done); Cryomodule Assembly Tooling (done); Installation Tolling (done)
- 13114020a: Steps: Q.A. Tooling (done); Cavity String Tooling (done); Cryomodule Assembly Tooling (done); Installation Tolling (done)

| ID | WBS | Activity | Duration | Start | Finish | Predecessors | Complete | Planned start | Planned finish | Resources | Cost | Actual cost | Calculated Remaining Total Cost | MONTHLY EV COST | RESP - Responsibility | STRT%COMP for CM EVM | FNSH%COMP for CM EVM | EVMS Reporting Codes | CAM RESPONSIBLE | CR 11-003 | CR 11-012 | CR 11-051 | CR 12-018 | CR 08-050 | CR 09-017 | CR 09-032 | CR 09-032 Repair | CR 10-023 | CR 10-027 | CR 10-064 |
| --- | --- | --- | --- | --- | --- | --- | --- | --- | --- | --- | --- | --- | --- | --- | --- | --- | --- | --- | --- | --- | --- | --- | --- | --- | --- | --- | --- | --- | --- | --- |
|  | 02 | **1.3.1.2.1.02 CAVITY STRING #2 PREPARATION** |  | 2011-01-12 | 2011-03-07 |  |  |  |  |  |  |  |  |  |  |  |  |  |  |  |  |  |  |  |  |  |  |  |  |  |
| 1312102002 |  | Cavity String #2 Cavity Processing | 32d | 2011-01-12 A | 2011-02-28 A | 1311122015, 1312101002 FS+20d, 1311122020 | 100% |  |  | SUPPLIES & MATERIALS; MECH ENG [12.4 h]; MECH TECH [178 h] | 17,589.04 | 8,509.04 | 0 | 17589.04 | HOGAN J | 1 | 1 | H | JOHN H | 11-003 | 11-012 | 11-051 | 12-018F |  |  |  |  |  |  |  |
| 1312102005 |  | Cavity String #2 Helium Vessel Welding | 27d | 2011-01-12 A | 2011-02-21 A | 131114080, 1311122015, 1312101005, 1311122020 | 100% | 2011-01-12 | 2011-02-18 | MECH ENG [8 h]; SUPPLIES & MATERIALS; MECH TECH [120 h]; ELEC TECH [8 h]; MECH DES [4 h] | 7,272.78 | 6,240.88 | 0 | 7272.78 | HOGAN J | 1 | 1 | H | JOHN H | 11-003 | 11-012 | 11-051 |  | 08-050 | 09-017 | 09-032 | 09-032 | 10-023 | 10-027 | 10-064 |
| 1312102030 |  | Cavity #9 VTA Run | 4d | 2011-01-17 A | 2011-01-21 A | 1312101065 FS-2d, 1312102005 FS-10d | 100% | 2011-01-18 | 2011-01-21 | COMP SCIENT [8 h]; ELEC ENG [8 h]; ELEC TECH [8 h]; MECH DES [8 h]; MECH ENG [8 h]; MECH TECH [8 h]; SCIENTIST [8 h]; SR STAFF [8 h] | 4,083.04 | 4,083.04 | 0 | 4083.04 | HOGAN J | 1 | 1 | H | JOHN H | 11-003 | 11-012 | 11-051 |  | 08-050 | 09-017 | 09-032 | 09-032 | 10-023 | 10-027 | 10-064 |
| 1312102035 |  | Cavity #10 VTA Run | 5d | 2011-01-24 A | 2011-01-28 A | 1312102030 FS-2d | 100% |  |  | MECH TECH [8 h]; SCIENTIST [8 h]; SR STAFF [8 h]; COMP SCIENT [8 h]; ELEC ENG [8 h]; ELEC TECH [8 h]; MECH ENG [8 h]; MECH DES [8 h] | 4,083.04 | 4,083.04 | 0 | 4083.04 | HOGAN J | 1 | 1 | H | JOHN H | 11-003 | 11-012 | 11-051 |  |  |  |  |  |  |  | 10-064 |
| 1312102040 |  | Cavity #11 VTA Run | 15d | 2011-01-31 A | 2011-02-21 A | 1312102035 FS-2d | 100% | 2011-01-31 | 2011-02-18 | ELEC ENG [8 h]; COMP SCIENT [8 h]; ELEC TECH [8 h]; MECH DES [8 h]; MECH ENG [8 h]; MECH TECH [8 h]; SCIENTIST [8 h]; SR STAFF [8 h] | 4,083.04 | 4,083.04 | 0 | 4083.04 | HOGAN J | 1 | 1 | H | JOHN H | 11-003 | 11-012 | 11-051 |  |  |  |  |  |  |  | 10-064 |
| 1312102045 |  | Cavity #12 VTA Run | 14d | 2011-02-01 A | 2011-02-21 A | 1312102040 FS-2d | 100% | 2011-02-01 | 2011-02-18 | SCIENTIST [8 h]; SR STAFF [8 h]; COMP SCIENT [8 h]; ELEC ENG [8 h]; ELEC TECH [8 h]; MECH DES [8 h]; MECH ENG [8 h]; MECH TECH [8 h] | 4,083.04 | 4,083.04 | 0 | 4083.04 | HOGAN J | 1 | 1 | H | JOHN H | 11-003 | 11-012 | 11-051 |  |  |  |  |  |  |  | 10-064 |
| 1312102050 |  | Cavity #13 VTA Run | 19d | 2011-02-01 A | 2011-02-28 A | 1312102045 FS-2d | 100% |  |  | SR STAFF [8 h]; COMP SCIENT [8 h]; ELEC ENG [8 h]; ELEC TECH [8 h]; MECH DES [8 h]; MECH ENG [8 h]; MECH TECH [8 h]; SCIENTIST [8 h] | 4,083.04 | 4,083.04 | 0 | 4083.04 | HOGAN J | 1 | 1 | H | JOHN H | 11-003 | 11-012 | 11-051 |  |  |  |  |  |  |  | 10-064 |
| 1312102055 |  | Cavity #14 VTA Run | 19d | 2011-02-01 A | 2011-02-28 A | 1312102050 FS-2d | 100% |  |  | MECH DES [8 h]; MECH ENG [8 h]; MECH TECH [8 h]; SCIENTIST [8 h]; SR STAFF [8 h]; COMP SCIENT [8 h]; ELEC ENG [8 h]; ELEC TECH [8 h] | 4,083.04 | 4,083.04 | 0 | 4083.04 | HOGAN J | 1 | 1 | H | JOHN H | 11-003 | 11-012 | 11-051 |  |  |  |  |  |  |  | 10-064 |
| 1312102060 |  | Cavity #15 VTA Run | 19d | 2011-02-01 A | 2011-02-28 A | 1312102055 FS-2d | 100% |  |  | ELEC TECH [8 h]; MECH DES [8 h]; MECH ENG [8 h]; MECH TECH [8 h]; SCIENTIST [8 h]; SR STAFF [8 h]; COMP SCIENT [8 h]; ELEC ENG [8 h] | 4,083.04 | 4,083.04 | 0 | 4083.04 | HOGAN J | 1 | 1 | H | JOHN H | 11-003 | 11-012 | 11-051 |  |  |  |  |  |  |  | 10-064 |
| 1312102065 |  | Cavity #16 VTA Run | 24d | 2011-02-01 A | 2011-03-07 A | 1312102060 FS-2d | 100% |  |  | COMP SCIENT [8 h]; ELEC ENG [8 h]; ELEC TECH [8 h]; MECH DES [8 h]; MECH ENG [8 h]; MECH TECH [8 h]; SCIENTIST [8 h]; SR STAFF [8 h] | 4,083.04 | 4,083.04 | 0 | 4083.04 | HOGAN J | 1 | 1 | H | JOHN H | 11-003 | 11-012 | 11-051 |  |  |  |  |  |  |  | 10-064 |
|  | 03 | **1.3.1.2.1.03 CAVITY STRING #3 PREPARATION** |  | 2011-02-01 | 2011-04-25 |  |  |  |  |  |  |  |  |  |  |  |  |  |  |  |  |  |  |  |  |  |  |  |  |  |
| 1312103005 |  | Cavity String #3 Cavity Process & He Vs Weld | 34d | 2011-02-01 A | 2011-03-21 A | 131114085, 1311122025, 1311122022, 1312102002, 1312102005 | 100% |  |  | MECH DES [4 h]; MECH ENG [20.4 h]; MECH TECH [298 h]; SUPPLIES & MATERIALS; ELEC TECH [8 h] | 24,861.92 | 14,749.92 | 0 | 24861.92 | HOGAN J | 1 | 1 | H | JOHN H | 11-003 | 11-012 | 11-051 | 12-018F | 08-050 | 09-017 | 09-032 | 09-032 | 10-023 | 10-027 | 10-064 |
| 1312103030 |  | Cavity #17 VTA Run | 19d | 2011-03-02 A | 2011-03-28 A | 1312102065 FS-2d, 1312103005 FS-10d | 100% |  |  | MECH DES [8 h]; MECH ENG [8 h]; MECH TECH [8 h]; SCIENTIST [8 h]; SR STAFF [8 h]; COMP SCIENT [8 h]; ELEC ENG [8 h]; ELEC TECH [8 h] | 4,083.04 | 4,083.04 | 0 | 4083.04 | HOGAN J | 1 | 1 | H | JOHN H | 11-003 | 11-012 | 11-051 | 12-018F | 08-050 | 09-017 | 09-032 | 09-032 | 10-023 | 10-027 | 10-064 |
| 1312103035 |  | Cavity #18 VTA Run | 19d | 2011-03-02 A | 2011-03-28 A | 1312103030 FS-2d | 100% |  |  | MECH ENG [8 h]; MECH TECH [8 h]; SCIENTIST [8 h]; SR STAFF [8 h]; COMP SCIENT [8 h]; ELEC ENG [8 h]; ELEC TECH [8 h]; MECH DES [8 h] | 4,083.04 | 4,083.04 | 0 | 4083.04 | HOGAN J | 1 | 1 | H | JOHN H | 11-003 | 11-012 | 11-051 | 12-018F |  |  |  |  |  |  | 10-064 |
| 1312103040 |  | Cavity #19 VTA Run | 19d | 2011-03-02 A | 2011-03-28 A | 1312103035 FS-2d | 100% |  |  | ELEC TECH [8 h]; MECH DES [8 h]; MECH ENG [8 h]; SR STAFF [8 h]; SCIENTIST [8 h]; MECH TECH [8 h]; COMP SCIENT [8 h]; ELEC ENG [8 h] | 4,083.04 | 4,083.04 | 0 | 4083.04 | HOGAN J | 1 | 1 | H | JOHN H | 11-003 | 11-012 | 11-051 | 12-018F |  |  |  |  |  |  | 10-064 |
| 1312103045 |  | Cavity #20 VTA Run | 19d | 2011-03-02 A | 2011-03-28 A | 1312103040 FS-2d | 100% |  |  | MECH ENG [8 h]; MECH TECH [8 h]; SCIENTIST [8 h]; SR STAFF [8 h]; COMP SCIENT [8 h]; ELEC ENG [8 h]; ELEC TECH [8 h]; MECH DES [8 h] | 4,083.04 | 4,083.04 | 0 | 4083.04 | HOGAN J | 1 | 1 | H | JOHN H | 11-003 | 11-012 | 11-051 | 12-018F |  |  |  |  |  |  | 10-064 |
| 1312103050 |  | Cavity #21 VTA Run | 19d | 2011-03-02 A | 2011-03-28 A | 1312103045 FS-2d | 100% |  |  | SCIENTIST [8 h]; SR STAFF [8 h]; COMP SCIENT [8 h]; ELEC ENG [8 h]; ELEC TECH [8 h]; MECH DES [8 h]; MECH ENG [8 h]; MECH TECH [8 h] | 4,083.04 | 4,083.04 | 0 | 4083.04 | HOGAN J | 1 | 1 | H | JOHN H | 11-003 | 11-012 | 11-051 | 12-018F |  |  |  |  |  |  | 10-064 |
| 1312103055 |  | Cavity #22 VTA Run | 19d | 2011-03-02 A | 2011-03-28 A | 1317005, 1312103050 FS-2d | 100% |  |  | SR STAFF [8 h]; COMP SCIENT [8 h]; ELEC ENG [8 h]; ELEC TECH [8 h]; MECH DES [8 h]; MECH ENG [8 h]; MECH TECH [8 h]; SCIENTIST [8 h] | 4,083.04 | 4,083.04 | 0 | 4083.04 | HOGAN J | 1 | 1 | H | JOHN H | 11-003 | 11-012 | 11-051 | 12-018F |  |  |  |  |  |  | 10-064 |
| 1312103060 |  | Cavity #23 VTA Run | 16d | 2011-04-02 A | 2011-04-25 A | 1312103055 FS-2d | 100% | 2011-04-04 | 2011-04-25 | ELEC ENG [8 h]; ELEC TECH [8 h]; MECH DES [8 h]; MECH ENG [8 h]; MECH TECH [8 h]; SCIENTIST [8 h]; SR STAFF [8 h]; COMP SCIENT [8 h] | 4,083.04 | 4,083.04 | 0 | 4083.04 | HOGAN J | 1 | 1 | H | JOHN H | 11-003 | 11-012 | 11-051 | 12-018F |  |  |  |  |  |  | 10-064 |
| 1312103065 |  | Cavity #24 VTA Run | 15d | 2011-04-05 A | 2011-04-25 A | 1312103060 FS-2d | 100% |  |  | ELEC ENG [8 h]; ELEC TECH [8 h]; MECH DES [8 h]; MECH TECH [8 h]; MECH ENG [8 h]; SCIENTIST [8 h]; SR STAFF [8 h]; COMP SCIENT [8 h] | 4,083.04 | 4,083.04 | 0 | 4083.04 | HOGAN J | 1 | 1 | H | JOHN H | 11-003 | 11-012 | 11-051 | 12-018F |  |  |  |  |  |  | 10-064 |
|  | 04 | **1.3.1.2.1.04 CAVITY STRING #4 PREPARATION** |  | 2011-03-02 | 2011-06-08 |  |  |  |  |  |  |  |  |  |  |  |  |  |  |  |  |  |  |  |  |  |  |  |  |  |
| 1312104005 |  | Cavity String #4 Cavity Process & He Vs Weld | 59d | 2011-03-02 A | 2011-05-23 A | 1311122030, 131114090, 1312103005, 1311122027 | 100% |  |  | MECH DES [4 h]; MECH ENG [20.4 h]; MECH TECH [298 h]; SUPPLIES & MATERIALS; ELEC TECH [8 h] | 24,861.92 | 14,749.92 | 0 | 24861.92 | HOGAN J | 1 | 1 | H | JOHN H | 11-003 | 11-012 | 11-051 | 12-018F | 08-050 | 09-017 | 09-032 | 09-032 | 10-023 | 10-027 | 10-064 |
| 1312104030 |  | Cavity#25 VTA Run | 16d | 2011-04-04 A | 2011-04-25 A | 1312103065 FS-2d, 1312104005 FS-10d | 100% |  |  | COMP SCIENT [8 h]; ELEC ENG [8 h]; ELEC TECH [8 h]; MECH DES [8 h]; MECH ENG [8 h]; MECH TECH [8 h]; SR STAFF [8 h]; SCIENTIST [8 h] | 4,083.04 | 4,083.04 | 0 | 4083.04 | HOGAN J | 1 | 1 | H | JOHN H | 11-003 | 11-012 | 11-051 | 12-018F | 08-050 | 09-017 | 09-032 | 09-032 | 10-023 | 10-027 | 10-064 |
| 1312104035 |  | Cavity#26 VTA Run | 5d | 2011-04-13 A | 2011-04-19 A | 1312104030 FS-2d | 100% |  |  | MECH TECH [8 h]; SR STAFF [8 h]; SCIENTIST [8 h]; COMP SCIENT [8 h]; ELEC ENG [8 h]; ELEC TECH [8 h]; MECH DES [8 h]; MECH ENG [8 h] | 4,083.04 | 4,083.04 | 0 | 4083.04 | HOGAN J | 1 | 1 | H | JOHN H | 11-003 | 11-012 | 11-051 | 12-018F |  |  |  |  |  |  | 10-064 |
| 1312104040 |  | Cavity#27 VTA Run | 5d | 2011-05-08 A | 2011-05-14 A | 1312104035 FS-2d | 100% | 2011-05-09 | 2011-05-13 | MECH TECH [8 h]; SR STAFF [8 h]; SCIENTIST [8 h]; COMP SCIENT [8 h]; ELEC ENG [8 h]; ELEC TECH [8 h]; MECH DES [8 h]; MECH ENG [8 h] | 4,083.04 | 4,083.04 | 0 | 4083.04 | HOGAN J | 1 | 1 | H | JOHN H | 11-003 | 11-012 | 11-051 | 12-018F |  |  |  |  |  |  | 10-064 |
| 1312104045 |  | Cavity#28 VTA Run | 3d | 2011-05-13 A | 2011-05-17 A | 1312104040 FS-2d | 100% |  |  | COMP SCIENT [8 h]; ELEC ENG [8 h]; ELEC TECH [8 h]; MECH DES [8 h]; MECH TECH [8 h]; SR STAFF [8 h]; SCIENTIST [8 h]; MECH ENG [8 h] | 4,083.04 | 4,083.04 | 0 | 4083.04 | HOGAN J | 1 | 1 | H | JOHN H | 11-003 | 11-012 | 11-051 | 12-018F |  |  |  |  |  |  | 10-064 |
| 1312104050 |  | Cavity#29 VTA Run | 5d | 2011-05-16 A | 2011-05-22 A | 1312104045 FS-2d | 100% | 2011-05-16 | 2011-05-20 | COMP SCIENT [8 h]; ELEC ENG [8 h]; ELEC TECH [8 h]; MECH DES [8 h]; MECH ENG [8 h]; MECH TECH [8 h]; SR STAFF [8 h]; SCIENTIST [8 h] | 4,083.04 | 4,083.04 | 0 | 4083.04 | HOGAN J | 1 | 1 | H | JOHN H | 11-003 | 11-012 | 11-051 | 12-018F |  |  |  |  |  |  | 10-064 |
| 1312104055 |  | Cavity#30 VTA Run | 5d | 2011-05-21 A | 2011-05-27 A | 1312104050 FS-2d | 100% | 2011-05-23 | 2011-05-27 | COMP SCIENT [8 h]; ELEC ENG [8 h]; ELEC TECH [8 h]; MECH DES [8 h]; MECH ENG [8 h]; MECH TECH [8 h]; SR STAFF [8 h]; SCIENTIST [8 h] | 4,083.04 | 4,083.04 | 0 | 4083.04 | HOGAN J | 1 | 1 | H | JOHN H | 11-003 | 11-012 | 11-051 | 12-018F |  |  |  |  |  |  | 10-064 |
| 1312104060 |  | Cavity#31 VTA Run | 4d | 2011-05-24 A | 2011-05-30 A | 1312104055 FS-2d | 100% | 2011-05-24 | 2011-05-27 | SCIENTIST [8 h]; COMP SCIENT [8 h]; ELEC ENG [8 h]; ELEC TECH [8 h]; MECH DES [8 h]; MECH ENG [8 h]; MECH TECH [8 h]; SR STAFF [8 h] | 4,083.04 | 4,083.04 | 0 | 4083.04 | HOGAN J | 1 | 1 | H | JOHN H | 11-003 | 11-012 | 11-051 | 12-018F |  |  |  |  |  |  | 10-064 |
| 1312104065 |  | Cavity#32 VTA Run | 6d | 2011-06-01 A | 2011-06-08 A | 1312104060 FS-2d | 100% |  |  | ELEC TECH [8 h]; SCIENTIST [8 h]; COMP SCIENT [8 h]; ELEC ENG [8 h]; MECH DES [8 h]; MECH ENG [8 h]; MECH TECH [8 h]; SR STAFF [8 h] | 4,083.04 | 4,083.04 | 0 | 4083.04 | HOGAN J | 1 | 1 | H | JOHN H | 11-003 | 11-012 | 11-051 | 12-018F |  |  |  |  |  |  | 10-064 |

| ID | WBS | Activity | Duration | Start | Finish | Predecessors | Complete | Planned start | Planned finish | Resources | Cost | Actual cost | Calculated Remaining Total Cost | MONTHLY EV COST | RESP - Responsibility | STRT%COMP for CM EVM | FNSH%COMP for CM EVM | EVMS Reporting Codes | CAM RESPONSIBLE | CR 08-050 | CR 09-017 | CR 09-032 | CR 09-032 Repair | CR 10-023 | CR 10-027 | CR 10-064 | CR 11-003 | CR 11-012 | CR 11-051 | CR 12-018 |
| --- | --- | --- | --- | --- | --- | --- | --- | --- | --- | --- | --- | --- | --- | --- | --- | --- | --- | --- | --- | --- | --- | --- | --- | --- | --- | --- | --- | --- | --- | --- |
|  | 05 | **1.3.1.2.1.05 CAVITY STRING #5 PREPARATION** |  | 2011-08-01 | 2011-09-28 |  |  |  |  |  |  |  |  |  |  |  |  |  |  |  |  |  |  |  |  |  |  |  |  |  |
| 1312105005 |  | Cavity String #5 Cavity Process & He Vs Weld | 11d | 2011-08-01 A | 2011-08-15 A | 1311122035, 131114095, 1311122065, 1312104005 | 100% |  |  | MECH TECH [298 h]; SUPPLIES & MATERIALS; ELEC TECH [8 h]; MECH DES [4 h]; MECH ENG [20.4 h] | 24,861.92 | 14,749.92 | 0 | 24861.92 | HOGAN J | 1 | 1 | H | JOHN H | 08-050 | 09-017 | 09-032 | 09-032 | 10-023 | 10-027 | 10-064 | 11-003 | 11-012 | 11-051 | 12-018F |
| 1312105030 |  | Cavity #33 VTA Run | 7d | 2011-08-12 A | 2011-08-22 A | 1312104065, 1312105005 FS-10d | 100% |  |  | COMP SCIENT [8 h]; ELEC ENG [8 h]; ELEC TECH [8 h]; MECH DES [8 h]; MECH ENG [8 h]; MECH TECH [8 h]; SCIENTIST [8 h]; SR STAFF [8 h] | 4,083.04 | 4,083.04 | 0 | 4083.04 | HOGAN J | 1 | 1 | H | JOHN H | 08-050 | 09-017 | 09-032 | 09-032 | 10-023 | 10-027 | 10-064 | 11-003 | 11-012 | 11-051 | 12-018F |
| 1312105035 |  | Cavity #34 VTA Run | 5d | 2011-08-15 A | 2011-08-21 A | 1312105030 FS-2d | 100% | 2011-08-15 | 2011-08-19 | MECH TECH [8 h]; SCIENTIST [8 h]; SR STAFF [8 h]; COMP SCIENT [8 h]; ELEC ENG [8 h]; ELEC TECH [8 h]; MECH DES [8 h]; MECH ENG [8 h] | 4,083.04 | 4,083.04 | 0 | 4083.04 | HOGAN J | 1 | 1 | H | JOHN H |  |  |  |  |  |  | 10-064 | 11-003 | 11-012 | 11-051 | 12-018F |
| 1312105040 |  | Cavity #35 VTA Run | 2d | 2011-09-03 A | 2011-09-07 A | 1312105035 FS-2d | 100% | 2011-09-06 | 2011-09-07 | MECH DES [8 h]; MECH ENG [8 h]; MECH TECH [8 h]; SCIENTIST [8 h]; COMP SCIENT [8 h]; ELEC ENG [8 h]; ELEC TECH [8 h]; SR STAFF [8 h] | 4,083.04 | 4,083.04 | 0 | 4083.04 | HOGAN J | 1 | 1 | H | JOHN H |  |  |  |  |  |  | 10-064 | 11-003 | 11-012 | 11-051 | 12-018F |
| 1312105045 |  | Cavity #36 VTA Run | 5d | 2011-09-06 A | 2011-09-12 A | 1312105040 FS-2d | 100% |  |  | COMP SCIENT [8 h]; ELEC ENG [8 h]; MECH ENG [8 h]; ELEC TECH [8 h]; MECH DES [8 h]; MECH TECH [8 h]; SCIENTIST [8 h]; SR STAFF [8 h] | 4,083.04 | 4,083.04 | 0 | 4083.04 | HOGAN J | 1 | 1 | H | JOHN H |  |  |  |  |  |  | 10-064 | 11-003 | 11-012 | 11-051 | 12-018F |
| 1312105050 |  | Cavity #37 VTA Run | 5d | 2011-09-11 A | 2011-09-17 A | 1312105045 FS-2d | 100% | 2011-09-12 | 2011-09-16 | MECH DES [8 h]; MECH ENG [8 h]; MECH TECH [8 h]; SCIENTIST [8 h]; SR STAFF [8 h]; COMP SCIENT [8 h]; ELEC ENG [8 h]; ELEC TECH [8 h] | 4,083.04 | 4,083.04 | 0 | 4083.04 | HOGAN J | 1 | 1 | H | JOHN H |  |  |  |  |  |  | 10-064 | 11-003 | 11-012 | 11-051 | 12-018F |
| 1312105055 |  | Cavity #38 VTA Run | 5d | 2011-09-14 A | 2011-09-20 A | 1312105050 FS-2d | 100% |  |  | MECH ENG [8 h]; MECH TECH [8 h]; SCIENTIST [8 h]; SR STAFF [8 h]; COMP SCIENT [8 h]; ELEC ENG [8 h]; ELEC TECH [8 h]; MECH DES [8 h] | 4,083.04 | 4,083.04 | 0 | 4083.04 | HOGAN J | 1 | 1 | H | JOHN H |  |  |  |  |  |  | 10-064 | 11-003 | 11-012 | 11-051 | 12-018F |
| 1312105060 |  | Cavity #39 VTA Run | 5d | 2011-09-19 A | 2011-09-25 A | 1312105055 FS-2d | 100% | 2011-09-19 | 2011-09-23 | MECH DES [8 h]; MECH ENG [8 h]; MECH TECH [8 h]; SCIENTIST [8 h]; SR STAFF [8 h]; COMP SCIENT [8 h]; ELEC ENG [8 h]; ELEC TECH [8 h] | 4,083.04 | 4,083.04 | 0 | 4083.04 | HOGAN J | 1 | 1 | H | JOHN H |  |  |  |  |  |  | 10-064 | 11-003 | 11-012 | 11-051 | 12-018F |
| 1312105065 |  | Cavity #40 VTA Run | 3d | 2011-09-24 A | 2011-09-28 A | 1312105060 FS-2d | 100% | 2011-09-26 | 2011-09-28 | MECH ENG [8 h]; MECH TECH [8 h]; SR STAFF [8 h]; COMP SCIENT [8 h]; ELEC ENG [8 h]; ELEC TECH [8 h]; MECH DES [8 h]; SCIENTIST [8 h] | 4,083.04 | 4,083.04 | 0 | 4083.04 | HOGAN J | 1 | 1 | H | JOHN H |  |  |  |  |  |  | 10-064 | 11-003 | 11-012 | 11-051 | 12-018F |
|  | 06 | **1.3.1.2.1.06 CAVITY STRING #6 PREPARATION** |  | 2011-08-29 | 2011-10-30 |  |  |  |  |  |  |  |  |  |  |  |  |  |  |  |  |  |  |  |  |  |  |  |  |  |
| 1312106005 |  | Cavity String #6 Cavity Process & He Vs Weld | 19d | 2011-08-29 A | 2011-09-24 A | 1312105005, 1311122067, 1311122070, 131114100 | 100% | 2011-08-29 | 2011-09-23 | MECH DES [4 h]; MECH ENG [20.4 h]; MECH TECH [298 h]; SUPPLIES & MATERIALS; ELEC TECH [8 h] | 24,861.92 | 14,749.92 | 0 | 24861.92 | HOGAN J | 1 | 1 | H | JOHN H | 08-050 | 09-017 | 09-032 | 09-032 |  | 10-027 | 10-064 | 11-003 | 11-012 | 11-051 | 12-018F |
| 1312106030 |  | Cavity #41 VTA Run | 8d | 2011-09-19 A | 2011-09-28 A | 1312106005 FS-10d, 1312105065 FS-2d | 100% |  |  | MECH ENG [8 h]; MECH TECH [8 h]; SCIENTIST [8 h]; SR STAFF [8 h]; COMP SCIENT [8 h]; ELEC ENG [8 h]; ELEC TECH [8 h]; MECH DES [8 h] | 4,083.04 | 4,083.04 | 0 | 4083.04 | HOGAN J | 1 | 1 | H | JOHN H | 08-050 | 09-017 | 09-032 | 09-032 | 10-023 | 10-027 | 10-064 | 11-003 | 11-012 | 11-051 | 12-018F |
| 1312106035 |  | Cavity #42 VTA Run | 4d | 2011-09-26 A | 2011-09-29 A | 1312106030 FS-2d | 100% |  |  | ELEC TECH [8 h]; SR STAFF [8 h]; MECH TECH [8 h]; SCIENTIST [8 h]; MECH DES [8 h]; MECH ENG [8 h]; COMP SCIENT [8 h]; ELEC ENG [8 h] | 4,083.04 | 4,083.04 | 0 | 4083.04 | HOGAN J | 1 | 1 | H | JOHN H |  |  |  |  |  |  | 10-064 | 11-003 | 11-012 | 11-051 | 12-018F |
| 1312106040 |  | Cavity #43 VTA Run | 5d | 2011-10-03 A | 2011-10-07 A | 1312106035 FS-2d | 100% |  |  | COMP SCIENT [8 h]; ELEC ENG [8 h]; ELEC TECH [8 h]; MECH DES [8 h]; MECH ENG [8 h]; SCIENTIST [8 h]; MECH TECH [8 h]; SR STAFF [8 h] | 4,213.2 | 4,213.2 | 0 | 4083.04 | HOGAN J | 1 | 1 | H | JOHN H |  |  |  |  |  |  | 10-064 | 11-003 | 11-012 | 11-051 | 12-018F |
| 1312106045 |  | Cavity #44 VTA Run | 5d | 2011-10-04 A | 2011-10-10 A | 1312106040 FS-2d | 100% |  |  | MECH DES [8 h]; MECH ENG [8 h]; MECH TECH [8 h]; SCIENTIST [8 h]; SR STAFF [8 h]; COMP SCIENT [8 h]; ELEC ENG [8 h]; ELEC TECH [8 h] | 4,213.2 | 4,213.2 | 0 | 4083.04 | HOGAN J | 1 | 1 | H | JOHN H |  |  |  |  |  |  | 10-064 | 11-003 | 11-012 | 11-051 | 12-018F |
| 1312106050 |  | Cavity #45 VTA Run | 5d | 2011-10-09 A | 2011-10-15 A | 1312106045 FS-2d | 100% | 2011-10-10 | 2011-10-14 | MECH ENG [8 h]; MECH TECH [8 h]; SCIENTIST [8 h]; SR STAFF [8 h]; COMP SCIENT [8 h]; ELEC ENG [8 h]; ELEC TECH [8 h]; MECH DES [8 h] | 4,213.2 | 4,213.2 | 0 | 4083.04 | HOGAN J | 1 | 1 | H | JOHN H |  |  |  |  |  |  | 10-064 | 11-003 | 11-012 | 11-051 | 12-018F |
| 1312106055 |  | Cavity #46 VTA Run | 3d | 2011-10-14 A | 2011-10-18 A | 1312106050 FS-2d | 100% |  |  | SR STAFF [8 h]; COMP SCIENT [8 h]; ELEC ENG [8 h]; ELEC TECH [8 h]; SCIENTIST [8 h]; MECH DES [8 h]; MECH ENG [8 h]; MECH TECH [8 h] | 4,213.2 | 4,213.2 | 0 | 4083.04 | HOGAN J | 1 | 1 | H | JOHN H |  |  |  |  |  |  | 10-064 | 11-003 | 11-012 | 11-051 | 12-018F |
| 1312106060 |  | Cavity #47 VTA Run | 5d | 2011-10-17 A | 2011-10-23 A | 1312106055 FS-2d | 100% | 2011-10-17 | 2011-10-21 | ELEC TECH [8 h]; MECH DES [8 h]; MECH ENG [8 h]; MECH TECH [8 h]; SCIENTIST [8 h]; SR STAFF [8 h]; COMP SCIENT [8 h]; ELEC ENG [8 h] | 4,213.2 | 4,213.2 | 0 | 4083.04 | HOGAN J | 1 | 1 | H | JOHN H |  |  |  |  |  |  | 10-064 | 11-003 | 11-012 | 11-051 | 12-018F |
| 1312106065 |  | Cavity #48 VTA Run | 5d | 2011-10-22 A | 2011-10-30 A | 1312106060 FS-2d | 100% | 2011-10-24 | 2011-10-28 | MECH DES [8 h]; MECH ENG [8 h]; MECH TECH [8 h]; SCIENTIST [8 h]; SR STAFF [8 h]; COMP SCIENT [8 h]; ELEC ENG [8 h]; ELEC TECH [8 h] | 4,213.2 | 4,213.2 | 0 | 4083.04 | HOGAN J | 1 | 1 | H | JOHN H |  |  |  |  |  |  | 10-064 | 11-003 | 11-012 | 11-051 | 12-018F |
|  | 07 | **1.3.1.2.1.07 CAVITY STRING #7 PREPARATION** |  | 2011-09-26 | 2011-11-20 |  |  |  |  |  |  |  |  |  |  |  |  |  |  |  |  |  |  |  |  |  |  |  |  |  |
| 1312107005 |  | Cavity String #7 Cavity Process & He Vs Weld | 20d | 2011-09-26 A | 2011-10-22 A | 1311122072, 1311122075, 1312106005, 131114105 | 100% | 2011-09-26 | 2011-10-21 | MECH ENG [20.4 h]; MECH TECH [298 h]; SUPPLIES & MATERIALS; ELEC TECH [8 h]; MECH DES [4 h] | 25,213.95 | 15,101.95 | 0 | 24861.92 | HOGAN J | 1 | 1 | H | JOHN H | 08-050 | 09-017 | 09-032 | 09-032 |  | 10-027 | 10-064 | 11-003 | 11-012 | 11-051 | 12-018F |
| 1312107030 |  | Cavity #49 VTA Run | 6d | 2011-10-17 A | 2011-10-24 A | 1312107005 FS-10d, 1312106065 FS-2d | 100% |  |  | ELEC TECH [8 h]; MECH DES [8 h]; MECH ENG [8 h]; MECH TECH [8 h]; SCIENTIST [8 h]; SR STAFF [8 h]; COMP SCIENT [8 h]; ELEC ENG [8 h] | 4,213.2 | 4,213.2 | 0 | 4083.04 | HOGAN J | 1 | 1 | H | JOHN H | 08-050 | 09-017 | 09-032 | 09-032 | 10-023 | 10-027 | 10-064 | 11-003 | 11-012 | 11-051 | 12-018F |
| 1312107035 |  | Cavity #50 VTA Run | 6d | 2011-10-17 A | 2011-10-24 A | 1312107030 FS-2d | 100% |  |  | MECH DES [8 h]; MECH ENG [8 h]; MECH TECH [8 h]; SCIENTIST [8 h]; COMP SCIENT [8 h]; ELEC ENG [8 h]; ELEC TECH [8 h]; SR STAFF [8 h] | 4,213.2 | 4,213.2 | 0 | 4083.04 | HOGAN J | 1 | 1 | H | JOHN H |  |  |  |  |  |  | 10-064 | 11-003 | 11-012 | 11-051 | 12-018F |
| 1312107040 |  | Cavity #51 VTA Run | 6d | 2011-10-17 A | 2011-10-24 A | 1312107035 FS-2d | 100% |  |  | MECH DES [8 h]; MECH ENG [8 h]; MECH TECH [8 h]; SCIENTIST [8 h]; SR STAFF [8 h]; COMP SCIENT [8 h]; ELEC ENG [8 h]; ELEC TECH [8 h] | 4,213.2 | 4,213.2 | 0 | 4083.04 | HOGAN J | 1 | 1 | H | JOHN H |  |  |  |  |  |  | 10-064 | 11-003 | 11-012 | 11-051 | 12-018F |
| 1312107045 |  | Cavity #52 VTA Run | 6d | 2011-10-24 A | 2011-10-31 A | 1312107040 FS-2d | 100% |  |  | SR STAFF [8 h]; COMP SCIENT [8 h]; ELEC ENG [8 h]; ELEC TECH [8 h]; MECH DES [8 h]; MECH ENG [8 h]; MECH TECH [8 h]; SCIENTIST [8 h] | 4,213.2 | 4,213.2 | 0 | 4083.04 | HOGAN J | 1 | 1 | H | JOHN H |  |  |  |  |  |  | 10-064 | 11-003 | 11-012 | 11-051 | 12-018F |
| 1312107050 |  | Cavity #53 VTA Run | 5d | 2011-11-01 A | 2011-11-07 A | 1312107045 FS-2d | 100% |  |  | MECH TECH [8 h]; SCIENTIST [8 h]; SR STAFF [8 h]; COMP SCIENT [8 h]; ELEC ENG [8 h]; ELEC TECH [8 h]; MECH DES [8 h]; MECH ENG [8 h] | 4,213.2 | 4,213.2 | 0 | 4083.04 | HOGAN J | 1 | 1 | H | JOHN H |  |  |  |  |  |  | 10-064 | 11-003 | 11-012 | 11-051 | 12-018F |
| 1312107055 |  | Cavity #54 VTA Run | 5d | 2011-11-06 A | 2011-11-12 A | 1312107050 FS-2d | 100% | 2011-11-07 | 2011-11-11 | MECH DES [8 h]; MECH ENG [8 h]; MECH TECH [8 h]; SCIENTIST [8 h]; SR STAFF [8 h]; COMP SCIENT [8 h]; ELEC ENG [8 h]; ELEC TECH [8 h] | 4,213.2 | 4,213.2 | 0 | 4083.04 | HOGAN J | 1 | 1 | H | JOHN H |  |  |  |  |  |  | 10-064 | 11-003 | 11-012 | 11-051 | 12-018F |
| 1312107060 |  | Cavity #55 VTA Run | 5d | 2011-11-09 A | 2011-11-15 A | 1312107055 FS-2d | 100% |  |  | ELEC TECH [8 h]; SR STAFF [8 h]; MECH DES [8 h]; MECH ENG [8 h]; MECH TECH [8 h]; SCIENTIST [8 h]; COMP SCIENT [8 h]; ELEC ENG [8 h] | 4,213.2 | 4,213.2 | 0 | 4083.04 | HOGAN J | 1 | 1 | H | JOHN H |  |  |  |  |  |  | 10-064 | 11-003 | 11-012 | 11-051 | 12-018F |
| 1312107065 |  | Cavity #56 VTA Run | 5d | 2011-11-14 A | 2011-11-20 A | 1312107060 FS-2d | 100% | 2011-11-14 | 2011-11-18 | MECH TECH [8 h]; SCIENTIST [8 h]; SR STAFF [8 h]; COMP SCIENT [8 h]; ELEC ENG [8 h]; ELEC TECH [8 h]; MECH DES [8 h]; MECH ENG [8 h] | 4,213.2 | 4,213.2 | 0 | 4083.04 | HOGAN J | 1 | 1 | H | JOHN H |  |  |  |  |  |  | 10-064 | 11-003 | 11-012 | 11-051 | 12-018F |

| ID | WBS | Activity | Duration | Start | Finish | Predecessors | Complete | Planned start | Planned finish | Resources | Cost | Actual cost | Calculated Remaining Total Cost | MONTHLY EV COST | RESP - Responsibility | STRT%COMP for CM EVM | FNSH%COMP for CM EVM | EVMS Reporting Codes | CAM RESPONSIBLE | CR 08-050 | CR 09-017 | CR 09-032 | CR 09-032 Repair | CR 10-027 | CR 10-064 | CR 11-003 | CR 11-012 | CR 11-051 | CR 12-018 |
| --- | --- | --- | --- | --- | --- | --- | --- | --- | --- | --- | --- | --- | --- | --- | --- | --- | --- | --- | --- | --- | --- | --- | --- | --- | --- | --- | --- | --- | --- |
|  | 08 | **1.3.1.2.1.08 CAVITY STRING #8 PREPARATION** |  | 2011-10-17 | 2011-11-25 |  |  |  |  |  |  |  |  |  |  |  |  |  |  |  |  |  |  |  |  |  |  |  |  |
| 1312108005 |  | Cavity String #8 Cavity Process & He Vs Weld | 16d | 2011-10-17 A | 2011-11-07 A | 1311122085, 131114110, 1311122080, 1312107005 | 100% |  |  | MECH DES [4 h]; MECH ENG [20.4 h]; MECH TECH [298 h]; SUPPLIES & MATERIALS; ELEC TECH [8 h] | 25,331.29 | 15,219.29 | 0 | 24861.92 | HOGAN J | 1 | 1 | H | JOHN H | 08-050 | 09-017 | 09-032 | 09-032 | 10-027 | 10-064 | 11-003 | 11-012 | 11-051 | 12-018F |
| 1312108030 |  | Cavity #57 VTA Run | 3d | 2011-11-08 A | 2011-11-10 A | 1312107065 FS-2d, 1312108005 FS-10d | 100% |  |  | MECH DES [8 h]; MECH ENG [8 h]; MECH TECH [8 h]; SCIENTIST [8 h]; SR STAFF [8 h]; COMP SCIENT [8 h]; ELEC ENG [8 h]; ELEC TECH [8 h] | 4,213.2 | 4,213.2 | 0 | 4083.04 | HOGAN J | 1 | 1 | H | JOHN H | 08-050 | 09-017 | 09-032 | 09-032 | 10-027 | 10-064 | 11-003 | 11-012 | 11-051 | 12-018F |
| 1312108035 |  | Cavity #58 VTA Run | 3d | 2011-11-10 A | 2011-11-14 A | 1312108030 FS-2d | 100% |  |  | MECH DES [8 h]; MECH ENG [8 h]; MECH TECH [8 h]; SCIENTIST [8 h]; SR STAFF [8 h]; COMP SCIENT [8 h]; ELEC ENG [8 h]; ELEC TECH [8 h] | 4,213.2 | 4,213.2 | 0 | 4083.04 | HOGAN J | 1 | 1 | H | JOHN H |  |  |  |  |  | 10-064 | 11-003 | 11-012 | 11-051 | 12-018F |
| 1312108040 |  | Cavity #59 VTA Run | 4d | 2011-11-14 A | 2011-11-17 A | 1312108035 FS-2d, 1317010 | 100% |  |  | MECH ENG [8 h]; MECH TECH [8 h]; SCIENTIST [8 h]; SR STAFF [8 h]; COMP SCIENT [8 h]; ELEC ENG [8 h]; ELEC TECH [8 h]; MECH DES [8 h] | 4,213.2 | 4,213.2 | 0 | 4083.04 | HOGAN J | 1 | 1 | H | JOHN H |  |  |  |  |  | 10-064 | 11-003 | 11-012 | 11-051 | 12-018F |
| 1312108045 |  | Cavity #60 VTA Run | 4d | 2011-11-14 A | 2011-11-17 A | 1312108040 FS-2d | 100% |  |  | MECH DES [8 h]; MECH ENG [8 h]; MECH TECH [8 h]; SCIENTIST [8 h]; SR STAFF [8 h]; COMP SCIENT [8 h]; ELEC ENG [8 h]; ELEC TECH [8 h] | 4,213.2 | 4,213.2 | 0 | 4083.04 | HOGAN J | 1 | 1 | H | JOHN H |  |  |  |  |  | 10-064 | 11-003 | 11-012 | 11-051 | 12-018F |
| 1312108050 |  | Cavity #61 VTA Run | 5d | 2011-11-14 A | 2011-11-18 A | 1312108045 FS-2d | 100% |  |  | MECH DES [8 h]; MECH ENG [8 h]; MECH TECH [8 h]; SCIENTIST [8 h]; SR STAFF [8 h]; COMP SCIENT [8 h]; ELEC ENG [8 h]; ELEC TECH [8 h] | 4,213.2 | 4,213.2 | 0 | 4083.04 | HOGAN J | 1 | 1 | H | JOHN H |  |  |  |  |  | 10-064 | 11-003 | 11-012 | 11-051 | 12-018F |
| 1312108055 |  | Cavity #62 VTA Run | 4d | 2011-11-16 A | 2011-11-21 A | 1312108050 FS-2d | 100% |  |  | SCIENTIST [8 h]; COMP SCIENT [8 h]; ELEC ENG [8 h]; ELEC TECH [8 h]; SR STAFF [8 h]; MECH DES [8 h]; MECH ENG [8 h]; MECH TECH [8 h] | 4,213.2 | 4,213.2 | 0 | 4083.04 | HOGAN J | 1 | 1 | H | JOHN H |  |  |  |  |  | 10-064 | 11-003 | 11-012 | 11-051 | 12-018F |
| 1312108060 |  | Cavity #63 VTA Run | 5d | 2011-11-17 A | 2011-11-24 A | 1312108055 FS-2d | 100% | 2011-11-17 | 2011-11-23 | MECH TECH [8 h]; SCIENTIST [8 h]; SR STAFF [8 h]; COMP SCIENT [8 h]; ELEC ENG [8 h]; ELEC TECH [8 h]; MECH DES [8 h]; MECH ENG [8 h] | 4,213.2 | 4,213.2 | 0 | 4083.04 | HOGAN J | 1 | 1 | H | JOHN H |  |  |  |  |  | 10-064 | 11-003 | 11-012 | 11-051 | 12-018F |
| 1312108065 |  | Cavity #64 VTA Run | 3d | 2011-11-21 A | 2011-11-25 A | 1312108060 FS-2d | 100% | 2011-11-21 | 2011-11-23 | ELEC TECH [8 h]; MECH DES [8 h]; MECH ENG [8 h]; MECH TECH [8 h]; SCIENTIST [8 h]; SR STAFF [8 h]; COMP SCIENT [8 h]; ELEC ENG [8 h] | 4,213.2 | 4,213.2 | 0 | 4083.04 | HOGAN J | 1 | 1 | H | JOHN H |  |  |  |  |  | 10-064 | 11-003 | 11-012 | 11-051 | 12-018F |
|  | 09 | **1.3.1.2.1.09 CAVITY STRING #9 PREPARATION** |  | 2011-11-14 | 2011-12-09 |  |  |  |  |  |  |  |  |  |  |  |  |  |  |  |  |  |  |  |  |  |  |  |  |
| 1312109005 |  | Cavity String #9 Cavity Process & He Vs Weld | 6d | 2011-11-14 A | 2011-11-21 A | 1311122087, 1311122090, 1312108005, 131114115 | 100% |  |  | MECH DES [4 h]; MECH ENG [20.4 h]; MECH TECH [298 h]; SUPPLIES & MATERIALS; ELEC TECH [8 h] | 25,331.29 | 15,219.29 | 0 | 24861.92 | HOGAN J | 1 | 1 | H | JOHN H | 08-050 | 09-017 | 09-032 | 09-032 | 10-027 | 10-064 | 11-003 | 11-012 | 11-051 | 12-018F |
| 1312109030 |  | Cavity #65 VTA Run | 2d | 2011-11-23 A | 2011-11-28 A | 1312109005 FS-10d, 1312108065 FS-2d | 100% |  |  | COMP SCIENT [8 h]; ELEC ENG [8 h]; ELEC TECH [8 h]; MECH DES [8 h]; MECH ENG [8 h]; MECH TECH [8 h]; SCIENTIST [8 h]; SR STAFF [8 h] | 4,213.2 | 4,213.2 | 0 | 4083.04 | HOGAN J | 1 | 1 | H | JOHN H | 08-050 | 09-017 | 09-032 | 09-032 | 10-027 | 10-064 | 11-003 |  | 11-051 | 12-018F |
| 1312109035 |  | Cavity #66 VTA Run | 3d | 2011-11-25 A | 2011-11-30 A | 1312109030 FS-2d | 100% | 2011-11-28 | 2011-11-30 | COMP SCIENT [8 h]; ELEC ENG [8 h]; ELEC TECH [8 h]; MECH DES [8 h]; MECH ENG [8 h]; MECH TECH [8 h]; SCIENTIST [8 h]; SR STAFF [8 h] | 4,213.2 | 4,213.2 | 0 | 4083.04 | HOGAN J | 1 | 1 | H | JOHN H |  |  |  |  |  | 10-064 | 11-003 |  | 11-051 | 12-018F |
| 1312109040 |  | Cavity #67 VTA Run | 3d | 2011-12-01 A | 2011-12-05 A | 1312109035 FS-2d | 100% |  |  | COMP SCIENT [8 h]; ELEC ENG [8 h]; ELEC TECH [8 h]; MECH DES [8 h]; MECH ENG [8 h]; MECH TECH [8 h]; SCIENTIST [8 h]; SR STAFF [8 h] | 4,213.2 | 4,213.2 | 0 | 4083.04 | HOGAN J | 1 | 1 | H | JOHN H |  |  |  |  |  | 10-064 | 11-003 |  | 11-051 | 12-018F |
| 1312109045 |  | Cavity #68 VTA Run | 2d | 2011-12-02 A | 2011-12-05 A | 1312109040 FS-2d | 100% |  |  | ELEC TECH [8 h]; MECH DES [8 h]; MECH ENG [8 h]; MECH TECH [8 h]; SCIENTIST [8 h]; COMP SCIENT [8 h]; ELEC ENG [8 h]; SR STAFF [8 h] | 4,213.2 | 4,213.2 | 0 | 4083.04 | HOGAN J | 1 | 1 | H | JOHN H |  |  |  |  |  | 10-064 | 11-003 |  | 11-051 | 12-018F |
| 1312109050 |  | Cavity #69 VTA Run | 3d | 2011-12-05 A | 2011-12-07 A | 1312109045 FS-2d | 100% |  |  | ELEC TECH [8 h]; MECH DES [8 h]; MECH ENG [8 h]; MECH TECH [8 h]; SCIENTIST [8 h]; SR STAFF [8 h]; COMP SCIENT [8 h]; ELEC ENG [8 h] | 4,213.2 | 4,213.2 | 0 | 4083.04 | HOGAN J | 1 | 1 | H | JOHN H |  |  |  |  |  | 10-064 | 11-003 |  | 11-051 | 12-018F |
| 1312109055 |  | Cavity #70 VTA Run | 4d | 2011-12-05 A | 2011-12-08 A | 1312109050 FS-2d | 100% |  |  | ELEC ENG [8 h]; ELEC TECH [8 h]; MECH DES [8 h]; MECH ENG [8 h]; MECH TECH [8 h]; SCIENTIST [8 h]; COMP SCIENT [8 h]; SR STAFF [8 h] | 4,213.2 | 4,213.2 | 0 | 4083.04 | HOGAN J | 1 | 1 | H | JOHN H |  |  |  |  |  | 10-064 | 11-003 |  | 11-051 | 12-018F |
| 1312109060 |  | Cavity #71 VTA Run | 3d | 2011-12-06 A | 2011-12-08 A | 1312109055 FS-2d | 100% |  |  | MECH DES [8 h]; MECH ENG [8 h]; MECH TECH [8 h]; SCIENTIST [8 h]; SR STAFF [8 h]; COMP SCIENT [8 h]; ELEC ENG [8 h]; ELEC TECH [8 h] | 4,213.2 | 4,213.2 | 0 | 4083.04 | HOGAN J | 1 | 1 | H | JOHN H |  |  |  |  |  | 10-064 | 11-003 |  | 11-051 | 12-018F |
| 1312109065 |  | Cavity #72 VTA Run | 3d | 2011-12-07 A | 2011-12-09 A | 1312109060 FS-2d | 100% |  |  | ELEC TECH [8 h]; MECH DES [8 h]; MECH ENG [8 h]; MECH TECH [8 h]; SCIENTIST [8 h]; SR STAFF [8 h]; COMP SCIENT [8 h]; ELEC ENG [8 h] | 4,213.2 | 4,213.2 | 0 | 4083.04 | HOGAN J | 1 | 1 | H | JOHN H |  |  |  |  |  | 10-064 | 11-003 |  | 11-051 | 12-018F |
|  | 10 | **1.3.1.2.1.10 CAVITY STRING #10 PREPARATION** |  | 2011-11-28 | 2012-02-07 |  |  |  |  |  |  |  |  |  |  |  |  |  |  |  |  |  |  |  |  |  |  |  |  |
| 1312110005 |  | Cavity String #10 Cavity Process & He Vs Weld | 11d | 2011-11-28 A | 2011-12-12 A | 131114125, 1311122092, 1311122100a, 1311122095, 131114130M, 131114120, 1311122100, 1312109005 | 100% |  |  | MECH DES [4 h]; MECH ENG [20.4 h]; MECH TECH [298 h]; ELEC TECH [8 h]; SUPPLIES & MATERIALS | 25,653.86 | 15,219.29 | 0 | 25653.858 | HOGAN J | 1 | 1 | H | JOHN H | 08-050 | 09-017 | 09-032 | 09-032 | 10-027 | 10-064 | 11-003 | 11-012 | 11-051 | 12-018F |
| 1312110030 |  | Cavity #73 VTA Run | 4d | 2011-12-12 A | 2011-12-15 A | 1312110005 FS-10d, 1312109065 FS-2d | 100% |  |  | ELEC TECH [8 h]; MECH DES [8 h]; MECH ENG [8 h]; MECH TECH [8 h]; SCIENTIST [8 h]; SR STAFF [8 h]; COMP SCIENT [8 h]; ELEC ENG [8 h] | 4,213.2 | 4,213.2 | 0 | 4213.2 | HOGAN J | 1 | 1 | H | JOHN H | 08-050 | 09-017 | 09-032 | 09-032 | 10-027 | 10-064 | 11-003 | 11-012 | 11-051 | 12-018F |
| 1312110035 |  | Cavity #74 VTA Run | 5d | 2011-12-12 A | 2011-12-16 A | 1312110030 FS-2d | 100% |  |  | MECH DES [8 h]; MECH ENG [8 h]; MECH TECH [8 h]; SCIENTIST [8 h]; SR STAFF [8 h]; COMP SCIENT [8 h]; ELEC ENG [8 h]; ELEC TECH [8 h] | 4,213.2 | 4,213.2 | 0 | 4213.2 | HOGAN J | 1 | 1 | H | JOHN H |  |  |  |  |  | 10-064 | 11-003 | 11-012 | 11-051 | 12-018F |
| 1312110040 |  | Cavity #75 VTA Run | 4d | 2012-01-03 A | 2012-01-07 A | 1312110035 FS-2d | 100% | 2012-01-03 | 2012-01-06 | ELEC TECH [8 h]; MECH DES [8 h]; MECH ENG [8 h]; MECH TECH [8 h]; SCIENTIST [8 h]; SR STAFF [8 h]; COMP SCIENT [8 h]; ELEC ENG [8 h] | 4,213.2 | 4,213.2 | 0 | 4213.2 | HOGAN J | 1 | 1 | H | JOHN H |  |  |  |  |  | 10-064 | 11-003 | 11-012 | 11-051 | 12-018F |
| 1312110045 |  | Cavity #76 VTA Run | 3d | 2012-01-06 A | 2012-01-10 A | 1312110040 FS-2d | 100% |  |  | COMP SCIENT [8 h]; ELEC TECH [8 h]; MECH DES [8 h]; MECH ENG [8 h]; MECH TECH [8 h]; SCIENTIST [8 h]; SR STAFF [8 h]; ELEC ENG [8 h] | 4,213.2 | 4,213.2 | 0 | 4213.2 | HOGAN J | 1 | 1 | H | JOHN H |  |  |  |  |  | 10-064 | 11-003 | 11-012 | 11-051 | 12-018F |
| 1312110050 |  | Cavity #77 VTA Run | 5d | 2012-01-09 A | 2012-01-15 A | 1312110045 FS-2d | 100% | 2012-01-09 | 2012-01-13 | MECH TECH [8 h]; SCIENTIST [8 h]; SR STAFF [8 h]; COMP SCIENT [8 h]; ELEC ENG [8 h]; ELEC TECH [8 h]; MECH DES [8 h]; MECH ENG [8 h] | 4,213.2 | 4,213.2 | 0 | 4213.2 | HOGAN J | 1 | 1 | H | JOHN H |  |  |  |  |  | 10-064 | 11-003 | 11-012 | 11-051 | 12-018F |
| 1312110055 |  | Cavity #78 VTA Run | 4d | 2012-01-14 A | 2012-01-21 A | 1312110050 FS-2d | 100% | 2012-01-17 | 2012-01-20 | COMP SCIENT [8 h]; ELEC ENG [8 h]; ELEC TECH [8 h]; MECH DES [8 h]; MECH ENG [8 h]; MECH TECH [8 h]; SCIENTIST [8 h]; SR STAFF [8 h] | 4,213.2 | 4,213.2 | 0 | 4213.2 | HOGAN J | 1 | 1 | H | JOHN H |  |  |  |  |  | 10-064 | 11-003 | 11-012 | 11-051 | 12-018F |
| 1312110060 |  | Cavity #79 VTA Run | 6d | 2012-01-17 A | 2012-01-24 A | 1312110055 FS-2d | 100% |  |  | SCIENTIST [8 h]; SR STAFF [8 h]; COMP SCIENT [8 h]; ELEC ENG [8 h]; ELEC TECH [8 h]; MECH DES [8 h]; MECH ENG [8 h]; MECH TECH [8 h] | 4,213.2 | 4,213.2 | 0 | 4213.2 | HOGAN J | 1 | 1 | H | JOHN H |  |  |  |  |  | 10-064 | 11-003 | 11-012 | 11-051 | 12-018F |
| 1312110065 |  | Cavity #80 VTA Run | 5d | 2012-02-01 A | 2012-02-07 A | 1312110060 FS-2d | 100% |  |  | COMP SCIENT [8 h]; ELEC ENG [8 h]; MECH DES [8 h]; ELEC TECH [8 h]; MECH ENG [8 h]; MECH TECH [8 h]; SCIENTIST [8 h]; SR STAFF [8 h] | 4,213.2 | 4,213.2 | 0 | 4213.2 | HOGAN J | 1 | 1 | H | JOHN H |  |  |  |  |  | 10-064 | 11-003 | 11-012 | 11-051 | 12-018F |

| ID | WBS | Activity | Duration | Start | Finish | Predecessors | Complete | Planned start | Planned finish | Resources | Cost | Actual cost | Calculated Remaining Total Cost | MONTHLY EV COST | RESP - Responsibility | STRT%COMP for CM EVM | FNSH%COMP for CM EVM | Profile change | EVMS Reporting Codes | CAM RESPONSIBLE | CR 08-050 | Activities with Steps | CR 09-017 | CR 09-032 | CR 09-032 Repair | CR 10-027 | CR 10-064 | CR 11-003 | CR 11-051 | CR 10-023 | CR 11-012 | CR 12-018 | CR 12-028 | CR 10-066 |
| --- | --- | --- | --- | --- | --- | --- | --- | --- | --- | --- | --- | --- | --- | --- | --- | --- | --- | --- | --- | --- | --- | --- | --- | --- | --- | --- | --- | --- | --- | --- | --- | --- | --- | --- |
|  | 2 | **1.3.1.2.2 DUMMY** |  |  |  |  |  |  |  |  |  |  |  |  |  |  |  |  |  |  |  |  |  |  |  |  |  |  |  |  |  |  |  |  |
|  | 3 | **1.3.1.2.3 DUMMY** |  |  |  |  |  |  |  |  |  |  |  |  |  |  |  |  |  |  |  |  |  |  |  |  |  |  |  |  |  |  |  |  |
|  | 4 | **1.3.1.2.4 STRING ASSEMBLY** |  | 2010-10-25 | 2012-02-20 |  |  |  |  |  |  |  |  |  |  |  |  |  |  |  |  |  |  |  |  |  |  |  |  |  |  |  |  |  |
|  | 01 | **1.3.1.2.4.01 CAVITY STRING ASSEMBLY #1** |  | 2010-10-25 | 2011-02-02 |  |  |  |  |  |  |  |  |  |  |  |  |  |  |  |  |  |  |  |  |  |  |  |  |  |  |  |  |  |
| 1312401000 |  | Cavity String Assy #1 | 35d | 2010-10-25 A | 2010-12-14 A | 1312101030 FS-15d, 1312101050a FS-30d, 131115015, 131116015, 1312101040 FS-20d, 32-03M, 1312101060 FS-35d, 1311132010, 1312101045 FS-20d, 131138040, 1312101035 FS-15d, 1312101050 FS-20d, 1312101065 FS-45d, 131137020, 1312101055 FS-35d | 100% |  |  | MECH DES [80 h]; MECH ENG [80 h]; MECH TECH [1200 h]; ELEC TECH [40 h]; COMP SCIENT [40 h]; SUPPLIES & MATERIALS; SCIENTIST [64 h]; SR STAFF [20 h]; ELEC ENG [200 h] | 102,362.07 | 85,354.52 | 0 | 102362.07 | HOGAN J | 1 | 1 | C | S | JOHN H | 08-050 | ST | 09-017 | 09-032 | 09-032 | 10-027 | 10-064 | 11-003 | 11-051 |  |  |  |  |  |
| 1312401010 |  | Transfer to CM #1 Assy | 2d | 2011-02-01 A | 2011-02-02 A | 1312401000 | 100% |  |  |  |  |  |  | 0 | HOGAN J | 1 | 1 |  | Z | JOHN H | 08-050 |  | 09-017 | 09-032 | 09-032 | 10-027 | 10-064 | 11-003 | 11-051 |  |  |  |  |  |
|  | 02 | **1.3.1.2.4.02 CAVITY STRING ASSEMBLY #2** |  | 2010-10-25 | 2011-04-19 |  |  |  |  |  |  |  |  |  |  |  |  |  |  |  |  |  |  |  |  |  |  |  |  |  |  |  |  |  |
| 1312402000 |  | Cavity String Assy #2 | 111d | 2010-10-25 A | 2011-04-11 A | 1312401010 FS-70d, 1312102060 FS-60d, 1312102050 FS-50d, 1312102040 FS-40d, 1312102030 FS-40d, 1311132015, 1312102065 FS-70d, 1312102035 FS-40d, 1312102045 FS-50d, 1311132020, 1312102055 FS-60d | 100% |  |  | SCIENTIST [64 h]; MECH TECH [1000 h]; SR STAFF [20 h]; ELEC ENG [200 h]; ELEC TECH [40 h]; MECH DES [80 h]; MECH ENG [80 h]; SUPPLIES & MATERIALS | 91,204.47 | 74,196.92 | 0 | 91204.47 | HOGAN J | 1 | 1 |  | S | JOHN H | 08-050 | ST | 09-017 | 09-032 | 09-032 | 10-027 | 10-064 | 11-003 | 11-051 | 10-023 | 11-012 |  |  |  |
| 1312402010 |  | Transfer to CM #2 Assy | 1d | 2011-04-19 A | 2011-04-19 A | 1312402000 FS+12d | 100% |  |  |  |  |  |  | 0 | HOGAN J | 1 | 1 |  | Z | JOHN H | 08-050 |  | 09-017 | 09-032 | 09-032 | 10-027 | 10-064 | 11-003 | 11-051 | 10-023 | 11-012 |  |  |  |
|  | 03 | **1.3.1.2.4.03 CAVITY STRING ASSEMBLY #3** |  | 2010-10-25 | 2011-06-22 |  |  |  |  |  |  |  |  |  |  |  |  |  |  |  |  |  |  |  |  |  |  |  |  |  |  |  |  |  |
| 1312403000 |  | Cavity String Assy #3 | 161d | 2010-10-25 A | 2011-06-21 A | 1312103065 FS-120d, 1312103040 FS-80d, 1312103045 FS-85d, 1312103050 FS-90d, 1312103060 FS-115d, 1311132030, 1312402010 FS-85d, 1312103055 FS-95d, 1312103035 FS-75d, 1311132025, 131302001 FS-140d, 1312103030 FS-70d | 100% |  |  | MECH DES [40 h]; SCIENTIST [64 h]; ELEC ENG [200 h]; SR STAFF [20 h]; MECH ENG [40 h]; MECH TECH [800 h]; SUPPLIES & MATERIALS; ELEC TECH [40 h] | 78,005.27 | 60,997.72 | 0 | 78005.27 | HOGAN J | 1 | 1 |  | S | JOHN H | 08-050 | ST | 09-017 | 09-032 | 09-032 | 10-027 | 10-064 | 11-003 | 11-051 |  | 11-012 | 12-018F | 12-028F |  |
| 1312403010 |  | Transfer to CM #3 Assy | 1d | 2011-06-22 A | 2011-06-22 A | 131302001, 1312403000 | 100% |  |  |  |  |  |  | 0 | HOGAN J | 1 | 1 |  | Z | JOHN H | 08-050 |  | 09-017 | 09-032 | 09-032 | 10-027 | 10-064 | 11-003 | 11-051 |  | 11-012 | 12-018F | 12-028F |  |
|  | 04 | **1.3.1.2.4.04 CAVITY STRING ASSEMBLY #4** |  | 2010-10-25 | 2011-08-12 |  |  |  |  |  |  |  |  |  |  |  |  |  |  |  |  |  |  |  |  |  |  |  |  |  |  |  |  |  |
| 1312404000 |  | Cavity String Assy #4 | 184d | 2010-10-25 A | 2011-07-25 A | 1312104045 FS-115d, 131302002 FS-160d, 1311132035, 1312403010 FS-140d, 1312104050 FS-115d, 131138045a FS-75d, 1312104055 FS-115d, 1312104060 FS-120d, 1312104030 FS-100d, 1312104035 FS-105d, 1312104065 FS-120d, 1311132040, 1312104040 FS-110d | 100% |  |  | ELEC TECH [40 h]; MECH TECH [800 h]; SUPPLIES & MATERIALS; SR STAFF [20 h]; MECH DES [40 h]; ELEC ENG [200 h]; MECH ENG [40 h]; SCIENTIST [64 h] | 78,005.27 | 60,997.72 | 0 | 78005.27 | HOGAN J | 1 | 1 |  | S | JOHN H | 08-050 | ST | 09-017 | 09-032 | 09-032 | 10-027 | 10-064 | 11-003 | 11-051 | 10-023 | 11-012 | 12-018F | 12-028F |  |
| 1312404010 |  | Transfer to CM #4 Assy | 1d | 2011-08-12 A | 2011-08-12 A | 1312404000, 131302002 | 100% |  |  |  |  |  |  | 0 | HOGAN J | 1 | 1 |  | Z | JOHN H | 08-050 |  | 09-017 | 09-032 | 09-032 | 10-027 | 10-064 | 11-003 | 11-051 | 10-023 | 11-012 | 12-018F | 12-028F |  |
|  | 05 | **1.3.1.2.4.05 CAVITY STRING ASSEMBLY #5** |  | 2010-10-25 | 2011-09-28 |  |  |  |  |  |  |  |  |  |  |  |  |  |  |  |  |  |  |  |  |  |  |  |  |  |  |  |  |  |
| 1312405000 |  | Cavity String Assy #5 | 229d | 2010-10-25 A | 2011-09-27 A | 1312105055 FS-170d, 131116016 FS-155d, 1312105040 FS-160d, 1312105065 FS-180d, 1311132045, 131115016, 1312105035 FS-160d, 1312404010 FS-180d, 1312105045 FS-165d, 131302003 FS-200d, 1312105030 FS-155d, 1312105050 FS-165d, 1312105060 FS-170d | 100% |  |  | MECH DES [40 h]; MECH ENG [40 h]; SCIENTIST [64 h]; SR STAFF [20 h]; ELEC ENG [200 h]; ELEC TECH [40 h]; MECH TECH [800 h]; SUPPLIES & MATERIALS | 78,005.27 | 60,997.72 | 0 | 78005.27 | HOGAN J | 1 | 1 |  | S | JOHN H | 08-050 | ST | 09-017 |  |  | 10-027 | 10-064 | 11-003 | 11-051 |  | 11-012 | 12-018F |  |  |
| 1312405010 |  | Transfer to CM #5 Assy | 1d | 2011-09-28 A | 2011-09-28 A | 131302003 FS-15d, 1312405000 | 100% |  |  |  |  |  |  | 0 | HOGAN J | 1 | 1 |  | Z | JOHN H | 08-050 |  | 09-017 |  |  | 10-027 | 10-064 |  | 11-051 |  | 11-012 | 12-018F | 12-028F | 10-066 |
|  | 06 | **1.3.1.2.4.06 CAVITY STRING ASSEMBLY #6** |  | 2010-10-25 | 2011-11-24 |  |  |  |  |  |  |  |  |  |  |  |  |  |  |  |  |  |  |  |  |  |  |  |  |  |  |  |  |  |
| 1312406000 |  | Cavity String Assy #6 | 268d | 2010-10-25 A | 2011-11-21 A | 1312106060 FS-205d, 1311132050, 1312106040 FS-195d, 1312106030 FS-190d, 1312106065 FS-210d, 1312405010 FS-210d, 1312106035 FS-195d, 1312106055 FS-205d, 131302004 FS-265d, 1312106045 FS-200d, 1312106050 FS-200d | 100% |  |  | MECH DES [40 h]; MECH ENG [40 h]; SR STAFF [20 h]; ELEC ENG [200 h]; ELEC TECH [40 h]; MECH TECH [800 h]; SUPPLIES & MATERIALS; SCIENTIST [64 h] | 78,266.16 | 61,258.61 | 0 | 78005.27 | HOGAN J | 1 | 1 |  | S | JOHN H | 08-050 | ST | 09-017 | 09-032 | 09-032 | 10-027 | 10-064 | 11-003 | 11-051 | 10-023 | 11-012 | 12-018F |  | 10-066 |
| 1312406010 |  | Transfer to CM #6 Assy | 1d | 2011-11-23 A | 2011-11-24 A | 1317010, 1312406000, 131302004 FS-55d | 100% | 2011-11-23 | 2011-11-23 |  |  |  |  | 0 | HOGAN J | 1 | 1 |  | Z | JOHN H | 08-050 |  | 09-017 | 09-032 | 09-032 | 10-027 | 10-064 | 11-003 | 11-051 | 10-023 | 11-012 | 12-018F |  | 10-066 |
|  | 07 | **1.3.1.2.4.07 CAVITY STRING ASSEMBLY #7** |  | 2010-10-25 | 2011-12-13 |  |  |  |  |  |  |  |  |  |  |  |  |  |  |  |  |  |  |  |  |  |  |  |  |  |  |  |  |  |
| 1312407000 |  | Cavity String Assy #7 | 282d | 2010-10-25 A | 2011-12-13 A | 1311132060, 131302005 FS-300d, 131138050 FS-180d, 1312107030 FS-185d, 1312107055 FS-195d, 1312107045 FS-190d, 1312107050 FS-195d, 1312107040 FS-190d, 1312107035 FS-185d, 1311132055, 1312406010 FS-235d, 1312107065 FS-200d, 1312107060 FS-200d | 100% |  |  | ELEC TECH [40 h]; MECH TECH [800 h]; SUPPLIES & MATERIALS; SR STAFF [20 h]; MECH DES [40 h]; MECH ENG [40 h]; SCIENTIST [64 h]; ELEC ENG [200 h] | 78,892.17 | 61,342.08 | 0 | 80489.93 | HOGAN J | 1 | 1 |  | S | JOHN H | 08-050 | ST | 09-017 |  |  | 10-027 | 10-064 | 11-003 | 11-051 |  | 11-012 | 12-018F |  | 10-066 |
| 1312407010 |  | Transfer to CM #7 Assy | 1d | 2011-12-13 A | 2011-12-13 A | 131302005 FS-40d, 1312407000 | 100% |  |  |  |  |  |  | 0 | HOGAN J | 1 | 1 |  | Z | JOHN H | 08-050 |  | 09-017 |  |  | 10-027 | 10-064 |  | 11-051 |  | 11-012 | 12-018F |  | 10-066 |

Notes:
- 1312401000: Steps: Purchase Hardware and store into kits (done); Assemble Cavities into a string (done)
- 1312402000: Steps: Purchase Hardware and store into kits (done); Assemble Cavities into a string (done)
- 1312403000: Steps: Purchase Hardware and store into kits (done); Assemble Cavities into a string (done)
- 1312404000: Steps: Purchase Hardware and store into kits (done); Assemble Cavities into a string (done)
- 1312405000: Steps: Purchase Hardware and store into kits (done); Assemble Cavities into a string (done)
- 1312406000: Steps: Purchase Hardware and store into kits (done); Assemble Cavities into a string (done)
- 1312407000: Steps: Purchase Hardware and store into kits (done); Assemble Cavities into a string (done)

| ID | WBS | Activity | Duration | Start | Finish | Predecessors | Complete | Planned start | Planned finish | Resources | Cost | Actual cost | Calculated Remaining Total Cost | MONTHLY EV COST | RESP - Responsibility | STRT%COMP for CM EVM | FNSH%COMP for CM EVM | EVMS Reporting Codes | CAM RESPONSIBLE | CR 08-050 | Activities with Steps | CR 09-017 | CR 09-032 | CR 09-032 Repair | CR 10-023 | CR 10-027 | CR 10-064 | CR 10-066 | CR 11-003 | CR 11-012 | CR 11-051 | CR 12-018 | CR 08-016 | CR 09-012 | CR 12-028 | CR 12-053 | CR 13-003 | Claimed Material Divider | ReBaseline Actuals Adjustment |
| --- | --- | --- | --- | --- | --- | --- | --- | --- | --- | --- | --- | --- | --- | --- | --- | --- | --- | --- | --- | --- | --- | --- | --- | --- | --- | --- | --- | --- | --- | --- | --- | --- | --- | --- | --- | --- | --- | --- | --- |
|  | 08 | **1.3.1.2.4.08 CAVITY STRING ASSEMBLY #8** |  | 2010-10-25 | 2012-01-24 |  |  |  |  |  |  |  |  |  |  |  |  |  |  |  |  |  |  |  |  |  |  |  |  |  |  |  |  |  |  |  |  |  |  |
| 1312408000 |  | Cavity String Assy #8 | 286d | 2010-10-25 A | 2011-12-19 A | 131302006 FS-360d, 1311132070 FS-20d, 1312108035 FS-220d, 1312108065 FS-240d, 1312108055 FS-235d, 1312108040 FS-225d, 1312108045 FS-225d, 1312407010 FS-260d, 1312108060 FS-235d, 1312108030 FS-220d, 1311132065 FS-15d, 1312108050 FS-230d | 100% |  |  | ELEC ENG [200 h]; ELEC TECH [40 h]; SUPPLIES & MATERIALS; SR STAFF [20 h]; MECH TECH [800 h]; MECH DES [40 h]; MECH ENG [40 h]; SCIENTIST [64 h] | 78,914.5 | 61,364.41 | 0 | 80489.93 | HOGAN J | 1 | 1 | S | JOHN H | 08-050 | ST | 09-017 | 09-032 | 09-032 | 10-023 | 10-027 | 10-064 | 10-066 | 11-003 | 11-012 | 11-051 | 12-018F |  |  |  |  |  |  |  |
| 1312408010 |  | Transfer to CM #8 Assy | 1d | 2012-01-24 A | 2012-01-24 A | 131302006 FS-110d, 1312408000 | 100% |  |  |  |  |  |  | 0 | HOGAN J | 1 | 1 | Z | JOHN H | 08-050 |  | 09-017 | 09-032 | 09-032 | 10-023 | 10-027 | 10-064 | 10-066 | 11-003 | 11-012 | 11-051 | 12-018F |  |  |  |  |  |  |  |
|  | 09 | **1.3.1.2.4.09 CAVITY STRING ASSEMBLY #9** |  | 2010-10-25 | 2012-01-18 |  |  |  |  |  |  |  |  |  |  |  |  |  |  |  |  |  |  |  |  |  |  |  |  |  |  |  |  |  |  |  |  |  |  |
| 1312409000 |  | Cavity String Assy #9 | 299d | 2010-10-25 A | 2012-01-16 A | 1312109055 FS-255d, 1311132080 FS-40d, 1312109030 FS-245d, 1312109035 FS-245d, 1312109050 FS-255d, 1312109065 FS-265d, 1312109060 FS-260d, 1312109045 FS-250d, 1311132075 FS-35d, 1312408010 FS-295d, 1312109040 FS-250d | 100% | 2010-10-25 | 2012-01-13 | ELEC ENG [200 h]; SCIENTIST [64 h]; SUPPLIES & MATERIALS; MECH TECH [800 h]; MECH DES [40 h]; ELEC TECH [40 h]; MECH ENG [40 h]; SR STAFF [20 h] | 78,983 | 61,432.91 | 0 | 80489.93 | HOGAN J | 1 | 1 | S | JOHN H | 08-050 | ST | 09-017 |  |  |  | 10-027 | 10-064 | 10-066 | 11-003 | 11-012 | 11-051 | 12-018F |  |  |  |  |  |  |  |
| 1312409010 |  | Transfer to CM #9 Assy | 2d | 2012-01-17 A | 2012-01-18 A | 1312409000 | 100% |  |  |  |  |  |  | 0 | HOGAN J | 1 | 1 | Z | JOHN H | 08-050 |  | 09-017 |  |  |  | 10-027 | 10-064 | 10-066 | 11-003 | 11-012 | 11-051 | 12-018F |  |  |  |  |  |  |  |
|  | 10 | **1.3.1.2.4.10 CAVITY STRING ASSEMBLY #10** |  | 2010-10-25 | 2012-02-20 |  |  |  |  |  |  |  |  |  |  |  |  |  |  |  |  |  |  |  |  |  |  |  |  |  |  |  |  |  |  |  |  |  |  |
| 1312410000 |  | Cavity String Assy #10 | 323d | 2010-10-25 A | 2012-02-20 A | 1311122105M FS-295d, 1311132090 FS-80d, 1312110035 FS-285d, 1312110040 FS-290d, 1312110045 FS-290d, 1312110030 FS-285d, 1312110060 FS-300d, 1312409010 FS-225d, 1312110065 FS-5d, 1312110055 FS-295d, 1311132100M FS-80d, 1312110050 FS-295d | 100% | 2010-10-25 | 2012-02-17 | SR STAFF [20 h]; SUPPLIES & MATERIALS; ELEC ENG [200 h]; ELEC TECH [40 h]; MECH TECH [800 h]; MECH DES [40 h]; MECH ENG [40 h]; SCIENTIST [64 h] | 79,094.97 | 61,544.89 | 0 | 80489.93 | HOGAN J | 1 | 1 | S | JOHN H | 08-050 | ST | 09-017 | 09-032 | 09-032 | 10-023 | 10-027 | 10-064 |  | 11-003 | 11-012 | 11-051 | 12-018F |  |  |  |  |  |  |  |
| 1312410010 |  | Transfer to CM #10 Assy | 5d | 2012-02-13 A | 2012-02-20 A | 131138055, 1312410000 | 100% | 2012-02-13 | 2012-02-17 |  |  |  |  | 0 | HOGAN J | 1 | 1 | Z | JOHN H | 08-050 |  | 09-017 | 09-032 | 09-032 | 10-023 | 10-027 |  |  |  |  | 11-051 | 12-018F |  |  |  |  |  |  |  |
|  | 3 | **1.3.1.3 CRYOMODULE ASSEMBLY** |  | 2011-01-21 | 2013-08-30 |  |  |  |  |  |  |  |  |  |  |  |  |  |  |  |  |  |  |  |  |  |  |  |  |  |  |  |  |  |  |  |  |  |  |
|  | 01 | **1.3.1.3.01 SPACE FRAME ASSEMBLY** |  | 2011-01-21 | 2013-08-30 |  |  |  |  |  |  |  |  |  |  |  |  |  |  |  |  |  |  |  |  |  |  |  |  |  |  |  |  |  |  |  |  |  |  |
| 131301001 |  | Space Frame Assy #1 | 61d | 2011-01-21 A | 2011-04-18 A | 131122017 FS-15d, 131123020 FS-15d, 131132020 FS-20d, 13114020a FS-70d, 131134015, 13114020, 131133020 FS-15d, 1312401010, 131121020 FS-20d, 13114015, 131122020 FS-15d, 131131020 | 100% |  |  | SUPPLIES & MATERIALS; MECH DES [160 h]; SCIENTIST [80 h]; COMP SCIENT [80 h]; MECH ENG [160 h]; MECH TECH [1600 h]; ELEC ENG [80 h]; SR STAFF [80 h]; ELEC TECH [320 h] | 136,051 | 125,732 | 0 | 136051 | HOGAN J | 1 | 1 | H | JOHN H | 08-050 |  | 09-017 | 09-032 | 09-032 |  | 10-027 | 10-064 |  | 11-003 |  | 11-051 | 12-018F | 08-016 | 09-012 |  |  |  |  |  |
| 131301002 |  | Space Frame Assy #2 | 46d | 2011-04-11 A | 2011-06-14 A | 131122020 FS-10d, 131122017 FS-10d, 131121021, 131122025 FS-10d, 131133025, 1312402010, 131123020 FS-10d, 131132020 FS-12.5d | 100% |  |  | MECH TECH [1600 h]; SUPPLIES & MATERIALS; SR STAFF [40 h]; ELEC ENG [40 h]; ELEC TECH [320 h]; MECH DES [80 h]; MECH ENG [80 h]; SCIENTIST [40 h] | 111,940.6 | 101,621.6 | 0 | 111940.6 | HOGAN J | 1 | 1 | H | JOHN H | 08-050 |  | 09-017 | 09-032 | 09-032 | 10-023 | 10-027 | 10-064 |  | 11-003 | 11-012 | 11-051 | 12-018F |  |  |  |  |  |  |  |
| 131301003 |  | Space Frame Assy #3 | 71d | 2011-06-01 A | 2011-09-11 A | 1312403010, 131122030, 131132020, 131133030, 131302001, 131121022, 131123020, 131122025 | 100% | 2011-06-01 | 2011-09-09 | SUPPLIES & MATERIALS; SCIENTIST [20 h]; SR STAFF [20 h]; ELEC ENG [40 h]; ELEC TECH [320 h]; MECH DES [40 h]; MECH ENG [40 h]; MECH TECH [1600 h] | 103,796.6 | 93,477.6 | 0 | 103796.6 | HOGAN J | 1 | 1 | H | JOHN H | 08-050 |  | 09-017 | 09-032 | 09-032 |  | 10-027 | 10-064 |  | 11-003 | 11-012 | 11-051 | 12-018F |  |  | 12-028F |  |  |  |  |
| 131301004 |  | Space Frame Assy #4 | 84d | 2011-08-12 A | 2011-12-12 A | 131122030 FS-15d, 131123025 FS-15d, 131121025 FS-25d, 131123016d, 131123016c, 131302002, 131122035 FS-15d, 131123016b, 1312404010, 131132025 FS-25d, 131133035 | 100% |  |  | SR STAFF [4 h]; SUPPLIES & MATERIALS; MECH TECH [1600 h]; ELEC ENG [16 h]; ELEC TECH [240 h]; MECH DES [4 h]; MECH ENG [40 h]; SCIENTIST [4 h] | 95,763.12 | 85,444.12 | 0 | 94206.36 | HOGAN J | 1 | 1 | H | JOHN H | 08-050 |  | 09-017 | 09-032 | 09-032 | 10-023 | 10-027 | 10-064 | 10-066 |  | 11-012 | 11-051 | 12-018F |  |  | 12-028F |  |  |  |  |
| 131301005 |  | Space Frame Assy #5 | 48d | 2011-09-20 A | 2011-11-28 A | 131122040 FS-10d, 1312405010 FS-20d, 131121026, 131131021b, 131132025 FS-20d, 131134016, 131122035 FS-10d, 131134018, 131302003 FS-45d, 131123025 FS-10d, 131133040 | 100% |  |  | MECH DES [4 h]; MECH ENG [40 h]; SCIENTIST [4 h]; ELEC ENG [16 h]; SR STAFF [4 h]; MECH TECH [1600 h]; ELEC TECH [240 h]; SUPPLIES & MATERIALS | 96,374.7 | 86,055.7 | 0 | 94206.36 | HOGAN J | 1 | 1 | H | JOHN H | 08-050 |  | 09-017 |  |  |  | 10-027 | 10-064 | 10-066 |  | 11-012 | 11-051 | 12-018F |  |  | 12-028F |  |  |  |  |
| 131301006 |  | Space Frame Assy #6 | 4d | 2012-02-01 A | 2012-02-06 A | 131122045 FS-5d, 131133045, 1312406010 FS+5d, 131132025 FS-10d, 131123025 FS-5d, 131301005, 131121027, 131122040 FS-5d, 131302004 | 100% |  |  | SCIENTIST [4 h]; ELEC ENG [16 h]; ELEC TECH [240 h]; SR STAFF [4 h]; MECH TECH [1600 h]; MECH DES [4 h]; MECH ENG [40 h]; SUPPLIES & MATERIALS | 97,204.26 | 86,556.08 | 0 | 97204.26 | HOGAN J | 1 | 1 | H | JOHN H | 08-050 |  | 09-017 | 09-032 | 09-032 | 10-023 | 10-027 | 10-064 | 10-066 | 11-003 | 11-012 | 11-051 | 12-018F |  |  |  |  |  |  |  |
| 131301006a |  | Space Frame Assy #6 Reverse entry | 4d | 2012-02-01 A | 2012-02-06 A | 9-120M FS+78d | 100% |  |  | MECH TECH [-1600 h]; SUPPLIES & MATERIALS; MECH DES [-4 h]; MECH ENG [-40 h]; SCIENTIST [-4 h]; ELEC ENG [-16 h]; ELEC TECH [-240 h]; SR STAFF [-4 h] | -97,204.26 | -86,556.08 |  |  | HOGAN J | 1 | 1 | H | JOHN H | 08-050 |  | 09-017 | 09-032 | 09-032 | 10-023 | 10-027 | 10-064 | 10-066 | 11-003 | 11-012 | 11-051 | 12-018 |  |  | 12-028F |  |  |  |  |
| 131301007 |  | Space Frame Assy #7 | 32d | 2012-02-01 A | 2012-03-18 A | 131123025, 131122045, 131122050, 131121028, 131132025, 131302005 FS-20d, 131133050, 1312407010 | 100% | 2012-02-01 | 2012-03-16 | SR STAFF [4 h]; MECH ENG [40 h]; ELEC TECH [240 h]; MECH TECH [1600 h]; ELEC ENG [16 h]; SUPPLIES & MATERIALS; MECH DES [4 h]; SCIENTIST [4 h] | 97,204.26 | 86,556.08 | 0 | 97204.26 | HOGAN J | 1 | 1 | H | JOHN H | 08-050 |  | 09-017 |  |  |  | 10-027 | 10-064 | 10-066 |  | 11-012 | 11-051 | 12-018 |  |  | 12-028F |  |  |  |  |
| 131301006b |  | Space Frame Assy #6 | 40d | 2012-03-03 A | 2012-04-27 A | 131302004, 131121027 FS-10d, 131301005 FS-15d, 1312406010, 131301006a FS+16d, 131122040 FS-5d, 131123025 FS-5d, 131122045 FS-5d, 131132025 FS-10d, 131133045 | 100% | 2012-03-05 | 2012-04-27 | MECH DES [4 h]; MECH ENG [40 h]; SCIENTIST [4 h]; ELEC ENG [16 h]; ELEC TECH [240 h]; SR STAFF [4 h]; MECH TECH [1600 h]; SUPPLIES & MATERIALS | 97,204.26 | 86,556.08 | 0 | 97204.26 | HOGAN J | 1 | 1 | H | JOHN H | 08-050 |  | 09-017 | 09-032 | 09-032 | 10-023 | 10-027 | 10-064 | 10-066 | 11-003 | 11-012 | 11-051 | 12-018 |  |  | 12-028F |  |  |  |  |
| 131301008 |  | Space Frame Assy #8 | 74d | 2012-05-01 A | 2012-08-14 A | 1312408010, 131122055 FS-20d, 131132030a, 131121029, 131132030 FS-20d, 131122050 FS-20d, 131133055, 131302007 FS-10d, 131123030 FS-20d | 100% |  |  | ELEC ENG [16 h]; ELEC TECH [240 h]; SR STAFF [4 h]; MECH ENG [40 h]; MECH TECH [1600 h]; SUPPLIES & MATERIALS; MECH DES [4 h]; SCIENTIST [4 h] | 97,204.26 | 86,556.08 | 0 | 97204.26 | HOGAN J | 1 | 1 | H | JOHN H | 08-050 |  | 09-017 | 09-032 | 09-032 | 10-023 | 10-027 | 10-064 | 10-066 | 11-003 | 11-012 | 11-051 | 12-018 |  |  | 12-028F |  |  |  |  |
| 131301009 |  | Space Frame Assy #9 | 45d | 2012-07-16 A | 2012-09-17 A | 131132030a FS-12.5d, 131133060, 131121030 FS-12.5d, 1317025 FS-40d, 131123030 FS-10d, 131302006b, 131122055 FS-10d, 131122060 FS-10d, 1312409010 | 100% |  |  | MECH DES [4 h]; MECH ENG [40 h]; MECH TECH [1600 h]; SCIENTIST [4 h]; SR STAFF [4 h]; ELEC ENG [16 h]; SUPPLIES & MATERIALS; ELEC TECH [240 h] | 97,204.26 | 86,556.08 | 0 | 97204.26 | HOGAN J | 1 | 1 | H | JOHN H | 08-050 |  | 09-017 |  |  |  | 10-027 | 10-064 | 10-066 |  | 11-012 | 11-051 | 12-018 |  |  | 12-028F |  |  |  |  |
| 131301010 |  | Space Frame Assy #10 FY12 | 69d | 2012-09-10 A | 2012-11-19 A | 131302008, 131122060, 131123030, 131132030, 131132030a, 131121010CLOE, 131121045LOE, 131121035, 131133065, 1312410010 | 100% | 2012-09-10 | 2012-12-17 | MECH TECH [779.49 h]; SCIENTIST [1.95 h]; MECH DES [1.95 h]; SR STAFF [1.95 h]; ELEC ENG [7.79 h]; ELEC TECH [116.92 h]; SUPPLIES & MATERIALS; MECH ENG [19.49 h] | 48,410.49 | 43,119.55 | 0 | 47356.0574 | HOGAN J | 1 | 1 | H | JOHN H | 08-050 |  | 09-017 | 09-032 | 09-032 | 10-023 | 10-027 | 10-064 | 10-066 | 11-003 | 11-012 | 11-051 | 12-018 |  |  | 12-028F | 12-053 |  |  |  |
| 131301010a |  | Space Frame Assy #10 FY13 | 69d | 2012-09-10 A | 2012-11-19 A | 131301010 FS-20d | 100% | 2012-09-10 | 2012-12-17 | MECH DES [3.05 h]; SR STAFF [3.05 h]; ELEC ENG [12.2 h]; ELEC TECH [182.9 h]; SUPPLIES & MATERIALS; MECH ENG [30.48 h]; MECH TECH [1219.28 h]; SCIENTIST [3.05 h] | 75,983.85 | 67,449.67 | 0 | 76442.0301 | HOGAN J | 1 | 1 | H | JOHN H | 08-050 |  | 09-017 | 09-032 | 09-032 | 10-023 | 10-027 | 10-064 | 10-066 | 11-003 | 11-012 | 11-051 | 12-018 |  |  | 12-028F | 12-053 | 13-003 |  |  |
| 131301015 |  | Re-Baseline Actuals Adjustment | 1d | 2013-08-30 A | 2013-08-30 A |  | 100% | 2013-09-03 | 2013-09-03 | PROCUREMENT>$50K 69 NO ESCALATION | -122,565.21 |  |  |  |  |  |  |  |  |  |  |  |  |  |  |  |  |  |  |  |  |  |  |  |  |  |  | 100 | ADJ |

Notes:
- 1312408000: Steps: Purchase Hardware and store into kits (done); Assemble Cavities into a string (done)
- 1312409000: Steps: Purchase Hardware and store into kits (done); Assemble Cavities into a string (done)
- 1312410000: Steps: Purchase Hardware and store into kits (done); Assemble Cavities into a string (done)
- 131301001: Corrective Actions: Modified lags to move start date of / construction

| ID | WBS | Activity | Duration | Start | Finish | Predecessors | Complete | Planned start | Planned finish | Resources | Cost | Actual cost | Calculated Remaining Total Cost | MONTHLY EV COST | RESP - Responsibility | STRT%COMP for CM EVM | FNSH%COMP for CM EVM | CR 08-016 | EVMS Reporting Codes | CAM RESPONSIBLE | CR 08-050 | CR 09-012 | CR 09-017 | CR 09-032 | CR 09-032 Repair | CR 10-027 | CR 10-064 | CR 11-003 | CR 11-051 | CR 12-018 | CR 10-023 | CR 11-012 | CR 12-028 | CR 10-066 | New H Claim | CR 12-053 | MARCH!!! | CR 13-003 | Remaining Material Cost Based on % Compl | Claimed Material Cost Based on % Complet | Initial Claimed Material Calc | Claimed Material Divider | ReBaseline Actuals Adjustment |
| --- | --- | --- | --- | --- | --- | --- | --- | --- | --- | --- | --- | --- | --- | --- | --- | --- | --- | --- | --- | --- | --- | --- | --- | --- | --- | --- | --- | --- | --- | --- | --- | --- | --- | --- | --- | --- | --- | --- | --- | --- | --- | --- | --- |
|  | 02 | **1.3.1.3.02 CRYOMODULE ASSEMBLY** |  | 2011-04-11 | 2013-08-30 |  |  |  |  |  |  |  |  |  |  |  |  |  |  |  |  |  |  |  |  |  |  |  |  |  |  |  |  |  |  |  |  |  |  |  |  |  |  |
| 131302001 |  | Cryomodule Assy #1 | 30d | 2011-04-11 A | 2011-05-21 A | 131131020, 131138020 FS-15d, 131136020 FS-15d, 131138030 FS-90d, 131137015, 131134015, 131138040, 131123020 FS-15d, 131139025, 131133070, 13114020a, 131137040 FS-45d, 131137030, 131132020 FS-20d, 131122017 FS-15d, 131122075, 13114015, 131135020a, 131301001, 13115015, 131122020 FS-15d, 13114020, 131135020 FS-25d, 131137050 | 100% | 2011-04-11 | 2011-05-20 | SR STAFF [80 h]; SUPPLIES & MATERIALS; ELEC TECH [320 h]; MECH DES [160 h]; SCIENTIST [80 h]; COMP SCIENT [80 h]; MECH ENG [160 h]; MECH TECH [1600 h]; ELEC ENG [80 h] | 136,051 | 125,732 | 0 | 136051 | HOGAN J | 1 | 1 | 08-016 | H | JOHN H | 08-050 | 09-012 | 09-017 | 09-032 | 09-032 | 10-027 | 10-064 | 11-003 | 11-051 | 12-018F |  |  |  |  |  |  |  |  |  |  |  |  |  |
| 131302002 |  | Cryomodule Assy #2 | 39d | 2011-06-15 A | 2011-08-09 A | 131136025, 131132020 FS-12.5d, 131301002, 131122017 FS-10d, 131122020 FS-10d, 131123020 FS-10d, 131138020 FS-10d, 131122080, 131135025, 131133075 FS-15d, 131302001 FS-15d, 131122025 FS-10d | 100% |  |  | MECH ENG [80 h]; MECH TECH [1600 h]; SUPPLIES & MATERIALS; SCIENTIST [40 h]; SR STAFF [40 h]; ELEC ENG [40 h]; ELEC TECH [320 h]; MECH DES [80 h] | 111,940.6 | 101,621.6 | 0 | 111940.6 | HOGAN J | 1 | 1 |  | H | JOHN H | 08-050 |  | 09-017 | 09-032 | 09-032 | 10-027 | 10-064 | 11-003 | 11-051 |  | 10-023 | 11-012 |  |  |  |  |  |  |  |  |  |  |  |
| 131302003 |  | Cryomodule Assy #3 | 29d | 2011-09-03 A | 2011-10-16 A | 131122085, 131135030, 131136030, 131122025, 131133080 FS-15d, 131301003, 131138020, 131122030, 131123020, 131132020 | 100% | 2011-09-06 | 2011-10-14 | SCIENTIST [20 h]; SR STAFF [20 h]; ELEC ENG [40 h]; ELEC TECH [320 h]; MECH DES [40 h]; MECH ENG [40 h]; MECH TECH [1600 h]; SUPPLIES & MATERIALS | 104,822.18 | 94,503.18 | 0 | 103796.6 | HOGAN J | 1 | 1 |  | H | JOHN H | 08-050 |  | 09-017 | 09-032 | 09-032 | 10-027 | 10-064 | 11-003 | 11-051 | 12-018F |  | 11-012 | 12-028F |  |  |  |  |  |  |  |  |  |  |
| 131302005 |  | Cryomodule Assy #5 | 41d | 2011-11-21 A | 2012-01-29 A | 131135040, 131134018, 131123025 FS-10d, 131134021LOE, 131122035 FS-10d, 131133090 FS-15d, 131134016, 131136040, 131131021b, 131301005, 131138020ba, 131132025 FS-20d, 131122095, 131122040 FS-10d | 100% | 2011-11-21 | 2012-01-27 | MECH ENG [40 h]; SR STAFF [4 h]; MECH TECH [1600 h]; ELEC TECH [240 h]; SUPPLIES & MATERIALS; MECH DES [4 h]; SCIENTIST [4 h]; ELEC ENG [16 h] | 97,204.26 | 86,556.08 | 0 | 97204.26 | HOGAN J | 1 | 1 |  | H | JOHN H | 08-050 |  | 09-017 |  |  | 10-027 | 10-064 |  | 11-051 | 12-018F |  | 11-012 | 12-028F | 10-066 |  |  |  |  |  |  |  |  |  |
| 131302004 |  | Cryomodule Assy #4 | 57d | 2011-12-13 A | 2012-03-12 A | 131136035, 9-120M, 131135035, 131123025 FS-15d, 131133085 FS-15d, 131138020, 131132025 FS-25d, 131122090, 131122030 FS-15d, 131301004 FS-20d, 131122035 FS-15d | 100% |  |  | SCIENTIST [4 h]; SR STAFF [4 h]; ELEC ENG [16 h]; ELEC TECH [240 h]; MECH DES [4 h]; MECH ENG [40 h]; MECH TECH [1600 h]; SUPPLIES & MATERIALS | 97,204.26 | 86,556.08 | 0 | 97204.26 | HOGAN J | 1 | 1 |  | H | JOHN H | 08-050 |  | 09-017 | 09-032 | 09-032 | 10-027 | 10-064 |  | 11-051 | 12-018F | 10-023 | 11-012 | 12-028F | 10-066 |  |  |  |  |  |  |  |  |  |
| 131302006 |  | Cryomodule Assy #6 | 4d | 2012-02-01 A | 2012-02-06 A | 131132025 FS-10d, 131122040 FS-5d, 131136045, 131122100, 131122045 FS-5d, 131133095, 131138020ba, 131301006, 131123025 FS-5d, 131135045 | 100% |  |  | MECH ENG [4 h]; SUPPLIES & MATERIALS; MECH DES [0.4 h]; SCIENTIST [0.4 h]; ELEC ENG [1.6 h]; ELEC TECH [24 h]; SR STAFF [0.4 h]; MECH TECH [160 h] | 9,720.43 | 8,655.61 | 0 | 9720.428 | HOGAN J | 1 | 1 |  | H | JOHN H | 08-050 |  | 09-017 | 09-032 | 09-032 | 10-027 | 10-064 | 11-003 | 11-051 | 12-018 | 10-023 | 11-012 |  | 10-066 |  |  |  |  |  |  |  |  |  |
| 131302006a |  | Cryomodule Assy #6 Reverse Entry | 4d | 2012-02-01 A | 2012-02-06 A | 9-120M FS+78d | 100% |  |  | SR STAFF [-0.4 h]; SUPPLIES & MATERIALS; MECH TECH [-160 h]; MECH DES [-0.4 h]; MECH ENG [-4 h]; SCIENTIST [-0.4 h]; ELEC ENG [-1.6 h]; ELEC TECH [-24 h] | -9,720.43 | -8,655.61 |  |  | HOGAN J | 1 | 1 |  | H | JOHN H | 08-050 |  | 09-017 | 09-032 | 09-032 | 10-027 | 10-064 | 11-003 | 11-051 | 12-018 | 10-023 | 11-012 | 12-028F | 10-066 |  |  |  |  |  |  |  |  |  |
| 131302007 |  | Cryomodule Assy #7 | 52d | 2012-03-02 A | 2012-05-14 A | 131138020d, 131122105, 131135050, 131122050, 131132025, 131136050, 131133100 FS-15d, 131301007, 131123025, 131122045 | 100% |  |  | SCIENTIST [4 h]; SR STAFF [4 h]; MECH ENG [40 h]; ELEC TECH [240 h]; MECH TECH [1600 h]; ELEC ENG [16 h]; SUPPLIES & MATERIALS; MECH DES [4 h] | 97,204.26 | 86,556.08 | 0 | 97204.26 | HOGAN J | 1 | 1 |  | H | JOHN H | 08-050 |  | 09-017 |  |  | 10-027 | 10-064 |  | 11-051 | 12-018 |  | 11-012 | 12-028F | 10-066 |  |  |  |  |  |  |  |  |  |
| 131302006b |  | Cryomodule Assy #6 | 56d | 2012-04-09 A | 2012-06-27 A | 131301006, 131301006b, 131122040 FS-5d, 131136045, 131302006a, 131122045 FS-5d, 131123025 FS-5d, 131135045, 131133095, 131122100, 131138020ba, 131132025 FS-10d | 100% |  |  | SUPPLIES & MATERIALS; MECH DES [4 h]; MECH ENG [40 h]; SCIENTIST [4 h]; ELEC ENG [16 h]; ELEC TECH [240 h]; SR STAFF [4 h]; MECH TECH [1600 h] | 97,204.26 | 86,556.08 | 0 | 97204.26 | HOGAN J | 1 | 1 |  | H | JOHN H | 08-050 |  | 09-017 | 09-032 | 09-032 | 10-027 | 10-064 | 11-003 | 11-051 | 12-018 | 10-023 | 11-012 | 12-028F | 10-066 |  |  |  |  |  |  |  |  |  |
| 131302008 |  | Cryomodule Assy #8 | 15d | 2012-08-20 A | 2012-09-10 A | 131136055, 131133105 FS-15d, 131132030a, 131122050 FS-20d, 131123030 FS-20d, 131138030 FS-20d, 1317025 FS-15d, 131122110, 131122055 FS-20d, 131135055, 131132030, 131301008, 131138020d | 100% |  |  | MECH ENG [40 h]; SCIENTIST [4 h]; ELEC ENG [16 h]; ELEC TECH [240 h]; SR STAFF [4 h]; MECH TECH [1600 h]; SUPPLIES & MATERIALS; MECH DES [4 h] | 97,204.26 | 86,556.08 | 0 | 97204.26 | HOGAN J | 1 | 1 |  | H | JOHN H | 08-050 |  | 09-017 | 09-032 | 09-032 | 10-027 | 10-064 | 11-003 | 11-051 | 12-018 | 10-023 | 11-012 | 12-028F | 10-066 | Aug 12 |  |  |  |  |  |  |  |  |
| 131302009 |  | Cryomodule Assy #9 FY12 | 68d | 2012-09-17 A | 2013-01-31 A | 131122060 FS-10d, 131123030 FS-10d, 131136060, 131138030 FS-10d, 131133110 FS-15d, 131122055 FS-10d, 131301009, 131132030a FS-20d, 131135060, 131138020g | 100% | 2012-09-17 | 2012-12-21 | ELEC TECH [120 h]; MECH TECH [800 h]; MECH DES [2 h]; MECH ENG [20 h]; SCIENTIST [2 h]; SR STAFF [2 h]; ELEC ENG [8 h]; SUPPLIES & MATERIALS | 49,781.56 | 44,507.18 | 0 | 48602.13 | HOGAN J | 1 | 1 |  | H | JOHN H | 08-050 |  | 09-017 |  |  | 10-027 | 10-064 |  | 11-051 | 12-018 |  | 11-012 | 12-028F | 10-066 |  | 12-053 | XX |  |  |  |  |  |  |
| 131302009a |  | Cryomodule Assy #9 FY13 | 68d | 2012-09-17 A | 2013-01-31 A | 131302009 FS-20d | 100% | 2012-09-17 | 2012-12-21 | SUPPLIES & MATERIALS; ELEC TECH [179.81 h]; MECH TECH [1198.78 h]; MECH DES [3 h]; MECH ENG [29.97 h]; SCIENTIST [3 h]; SR STAFF [3 h]; ELEC ENG [11.99 h] | 74,850.6 | 66,692.68 | 0 | 75155.6907 | HOGAN J | 1 | 1 |  | H | JOHN H | 08-050 |  | 09-017 |  |  | 10-027 | 10-064 |  | 11-051 | 12-018 |  | 11-012 | 12-028F | 10-066 |  | 12-053 | XX | 13-003 |  |  |  |  |  |
| 131302010 |  | Cryomodule Assy #10 | 28d | 2012-12-17 A | 2013-03-11 A | 131301010 FS-15d, 131135065, 131138065LOE, 131122065R, 131133115a, 131133130LOE, 131132030, 131132030a, 131122060, 131123030, 131138020g, 131138030, 131301010a FS-15d, 131136065 | 100% | 2013-01-02 | 2013-02-11 | SUPPLIES & MATERIALS; MECH ENG [59.94 h]; MECH TECH [2397.53 h]; SCIENTIST [5.99 h]; MECH DES [5.99 h]; SR STAFF [5.99 h]; ELEC ENG [23.98 h]; ELEC TECH [359.63 h] | 150,309.19 | 133,844.35 | 0 | 150308.9865 | HOGAN J | 1 | 1 |  | H | JOHN H | 08-050 |  | 09-017 | 09-032 | 09-032 | 10-027 | 10-064 | 11-003 | 11-051 | 12-018 | 10-023 | 11-012 | 12-028F | 10-066 |  |  | XX | 13-003 |  |  |  |  |  |
| 131302015 |  | Re-Baseline Actuals Adjustment | 1d | 2013-08-30 A | 2013-08-30 A |  | 100% | 2013-09-03 | 2013-09-03 | PROCUREMENT>$50K 69 NO ESCALATION | 59,440.84 |  |  | 59440.84 |  |  |  |  |  |  |  |  |  |  |  |  |  |  |  |  |  |  |  |  |  |  |  |  | 0 | 59440.84 | 5944084 | 100 | ADJ |
|  | 03 | **1.3.1.3.03 N/A** |  |  |  |  |  |  |  |  |  |  |  |  |  |  |  |  |  |  |  |  |  |  |  |  |  |  |  |  |  |  |  |  |  |  |  |  |  |  |  |  |  |
|  | 04 | **1.3.1.3.04 N/A** |  |  |  |  |  |  |  |  |  |  |  |  |  |  |  |  |  |  |  |  |  |  |  |  |  |  |  |  |  |  |  |  |  |  |  |  |  |  |  |  |  |
|  | 05 | **1.3.1.3.05 N/A** |  |  |  |  |  |  |  |  |  |  |  |  |  |  |  |  |  |  |  |  |  |  |  |  |  |  |  |  |  |  |  |  |  |  |  |  |  |  |  |  |  |
|  | 06 | **1.3.1.3.06 N/A** |  |  |  |  |  |  |  |  |  |  |  |  |  |  |  |  |  |  |  |  |  |  |  |  |  |  |  |  |  |  |  |  |  |  |  |  |  |  |  |  |  |
|  | 07 | **1.3.1.3.07 N/A** |  |  |  |  |  |  |  |  |  |  |  |  |  |  |  |  |  |  |  |  |  |  |  |  |  |  |  |  |  |  |  |  |  |  |  |  |  |  |  |  |  |
|  | 08 | **1.3.1.3.08 N/A** |  |  |  |  |  |  |  |  |  |  |  |  |  |  |  |  |  |  |  |  |  |  |  |  |  |  |  |  |  |  |  |  |  |  |  |  |  |  |  |  |  |
|  | 09 | **1.3.1.3.09 N/A** |  |  |  |  |  |  |  |  |  |  |  |  |  |  |  |  |  |  |  |  |  |  |  |  |  |  |  |  |  |  |  |  |  |  |  |  |  |  |  |  |  |
|  | 10 | **1.3.1.3.10 N/A** |  |  |  |  |  |  |  |  |  |  |  |  |  |  |  |  |  |  |  |  |  |  |  |  |  |  |  |  |  |  |  |  |  |  |  |  |  |  |  |  |  |
|  | 1 | **(New WBS)** |  |  |  |  |  |  |  |  |  |  |  |  |  |  |  |  |  |  |  |  |  |  |  |  |  |  |  |  |  |  |  |  |  |  |  |  |  |  |  |  |  |
|  | 4 | **1.3.1.4 CRYOMODULE ACCEPTANCE TEST** |  | 2011-06-01 | 2013-08-30 |  |  |  |  |  |  |  |  |  |  |  |  |  |  |  |  |  |  |  |  |  |  |  |  |  |  |  |  |  |  |  |  |  |  |  |  |  |  |
| 1314000 |  | Re-Baseline Actuals Adjustment | 1d | 2013-08-30 A | 2013-08-30 A |  | 100% | 2013-09-03 | 2013-09-03 | PROCUREMENT>$50K 69 NO ESCALATION | -5,229.75 |  |  |  |  |  |  |  |  |  |  |  |  |  |  |  |  |  |  |  |  |  |  |  |  |  |  |  |  |  |  | 100 | ADJ |

Notes:
- 131302001: Corrective Actions: Modified lags to move start date of / construction

| ID | WBS | Activity | Duration | Start | Finish | Predecessors | Complete | Planned start | Planned finish | Resources | Cost | Actual cost | Calculated Remaining Total Cost | MONTHLY EV COST | RESP - Responsibility | STRT%COMP for CM EVM | FNSH%COMP for CM EVM | EVMS Reporting Codes | CAM RESPONSIBLE | CR 08-050 | CR 09-017 | CR 09-032 | CR 09-032 Repair | CR 10-031 | CR 10-064 | CR 10-065 | CR 10-066 | CR 11-012 | CR 11-051 | CR 12-018 | CR 12-028 | CR 10-023 | Specification | CR 11-003 | MARCH!!! | CR 12-053 | OPC Allison | CR 13-003 | CR 10-027 | Remaining Material Cost Based on % Compl | Claimed Material Cost Based on % Complet | Initial Claimed Material Calc | Claimed Material Divider | ReBaseline Actuals Adjustment |
| --- | --- | --- | --- | --- | --- | --- | --- | --- | --- | --- | --- | --- | --- | --- | --- | --- | --- | --- | --- | --- | --- | --- | --- | --- | --- | --- | --- | --- | --- | --- | --- | --- | --- | --- | --- | --- | --- | --- | --- | --- | --- | --- | --- | --- |
|  | 01 | **1.3.1.4.01 CRYOMODULE ACCEPTANCE TEST #1** |  | 2011-06-01 | 2011-08-15 |  |  |  |  |  |  |  |  |  |  |  |  |  |  |  |  |  |  |  |  |  |  |  |  |  |  |  |  |  |  |  |  |  |  |  |  |  |  |  |
| 131401000 |  | Acceptance Test Cryomodule #1 | 53d | 2011-06-01 A | 2011-08-15 A | 131302001, 131116025 | 100% |  |  | COMP SCIENT [80 h]; ELEC ENG [240 h]; SCIENTIST [200 h]; ELEC TECH [120 h]; MECH ENG [120 h]; MECH TECH [200 h]; SUPPLIES & MATERIALS; SR STAFF [200 h] | 84,146.3 | 78,986.8 | 0 | 84146.3 | HOGAN J | 1 | 1 | H | JOHN H | 08-050 | 09-017 | 09-032 | 09-032 | 10-031 | 10-064 | 10-065 | 10-066 |  |  |  |  |  |  |  |  |  |  |  |  |  |  |  |  |  |
|  | 02 | **1.3.1.4.02 CRYOMODULE ACCEPTANCE TEST #2** |  | 2011-08-15 | 2011-09-14 |  |  |  |  |  |  |  |  |  |  |  |  |  |  |  |  |  |  |  |  |  |  |  |  |  |  |  |  |  |  |  |  |  |  |  |  |  |  |  |
| 131402000 |  | Acceptance Test Cryomodule #2 | 22d | 2011-08-15 A | 2011-09-14 A | 131401000, 131302002 | 100% |  |  | SR STAFF [120 h]; ELEC ENG [240 h]; ELEC TECH [120 h]; COMP SCIENT [60 h]; MECH ENG [80 h]; MECH TECH [160 h]; SUPPLIES & MATERIALS; SCIENTIST [120 h] | 64,198.5 | 59,039 | 0 | 64198.5 | HOGAN J | 1 | 1 | H | JOHN H | 08-050 | 09-017 | 09-032 | 09-032 | 10-031 | 10-064 | 10-065 | 10-066 | 11-012 |  |  |  |  |  |  |  |  |  |  |  |  |  |  |  |  |
|  | 03 | **1.3.1.4.03 CRYOMODULE ACCEPTANCE TEST #3** |  | 2011-10-17 | 2011-12-19 |  |  |  |  |  |  |  |  |  |  |  |  |  |  |  |  |  |  |  |  |  |  |  |  |  |  |  |  |  |  |  |  |  |  |  |  |  |  |  |
| 131403000 |  | Acceptance Test Cryomodule #3 | 44d | 2011-10-17 A | 2011-12-19 A | 131302003, 9-120M FS+21d, 131402000 | 100% |  |  | SCIENTIST [40 h]; ELEC TECH [120 h]; SR STAFF [40 h]; ELEC ENG [240 h]; COMP SCIENT [40 h]; MECH ENG [80 h]; MECH TECH [160 h]; SUPPLIES & MATERIALS | 50,243.29 | 44,919.2 | 0 | 50243.29 | HOGAN J | 1 | 1 | H | JOHN H | 08-050 | 09-017 | 09-032 | 09-032 | 10-031 | 10-064 |  | 10-066 | 11-012 | 11-051 | 12-018F | 12-028F |  |  |  |  |  |  |  |  |  |  |  |  |  |
|  | 04 | **1.3.1.4.04 CRYOMODULE ACCEPTANCE TEST #4** |  | 2012-02-01 | 2012-05-14 |  |  |  |  |  |  |  |  |  |  |  |  |  |  |  |  |  |  |  |  |  |  |  |  |  |  |  |  |  |  |  |  |  |  |  |  |  |  |  |
| 131404000 |  | Acceptance Test Cryomodule #4 | 4d | 2012-02-01 A | 2012-02-06 A | 131302004, 131403000 | 100% |  |  | SUPPLIES & MATERIALS; SCIENTIST [40 h]; SR STAFF [40 h]; ELEC ENG [240 h]; ELEC TECH [120 h]; COMP SCIENT [40 h]; MECH ENG [80 h]; MECH TECH [160 h] | 50,243.29 | 44,919.2 | 0 | 50243.29 | HOGAN J | 1 | 1 | H | JOHN H | 08-050 | 09-017 | 09-032 | 09-032 | 10-031 | 10-064 |  | 10-066 | 11-012 | 11-051 | 12-018F | 12-028F | 10-023 |  |  |  |  |  |  |  |  |  |  |  |  |
| 131404005 |  | Acceptance Test Cryomodule #4 Reverse Entry | 4d | 2012-02-01 A | 2012-02-06 A | 9-120M FS+78d | 100% |  |  | MECH TECH [-160 h]; SUPPLIES & MATERIALS; SCIENTIST [-40 h]; SR STAFF [-40 h]; ELEC ENG [-240 h]; ELEC TECH [-120 h]; COMP SCIENT [-40 h]; MECH ENG [-80 h] | -50,243.29 | -44,919.2 |  |  | HOGAN J | 1 | 1 | P | JOHN H | 08-050 | 09-017 | 09-032 | 09-032 | 10-031 | 10-064 |  | 10-066 | 11-012 | 11-051 | 12-018 | 12-028F | 10-023 |  |  |  |  |  |  |  |  |  |  |  |  |
| 131404010 |  | Acceptance Test Cryomodule #4 | 26d | 2012-04-09 A | 2012-05-14 A | 131302004, 131404005, 131405000 FS+1d, 131403000 | 100% |  |  | SCIENTIST [40 h]; SR STAFF [40 h]; ELEC ENG [240 h]; ELEC TECH [120 h]; COMP SCIENT [40 h]; MECH ENG [80 h]; MECH TECH [160 h]; SUPPLIES & MATERIALS | 50,243.29 | 44,919.2 | 0 | 50243.29 | HOGAN J | 1 | 1 | H | JOHN H | 08-050 | 09-017 | 09-032 | 09-032 | 10-031 | 10-064 |  | 10-066 | 11-012 | 11-051 | 12-018 | 12-028F | 10-023 |  |  |  |  |  |  |  |  |  |  |  |  |
|  | 05 | **1.3.1.4.05 CRYOMODULE ACCEPTANCE TEST #5** |  | 2012-01-16 | 2012-02-23 |  |  |  |  |  |  |  |  |  |  |  |  |  |  |  |  |  |  |  |  |  |  |  |  |  |  |  |  |  |  |  |  |  |  |  |  |  |  |  |
| 131405000 |  | Acceptance Test Cryomodule #5 | 27d | 2012-01-16 A | 2012-02-23 A | 131302005, 131404000 FS-35d | 100% | 2012-01-17 | 2012-02-23 | MECH TECH [160 h]; SUPPLIES & MATERIALS; SCIENTIST [40 h]; SR STAFF [40 h]; ELEC TECH [120 h]; COMP SCIENT [40 h]; ELEC ENG [240 h]; MECH ENG [80 h] | 50,243.29 | 44,919.2 | 0 | 50243.29 | HOGAN J | 1 | 1 | H | JOHN H | 08-050 | 09-017 |  |  | 10-031 | 10-064 |  | 10-066 | 11-012 | 11-051 | 12-018 | 12-028F |  |  |  |  |  |  |  |  |  |  |  |  |  |
|  | 06 | **1.3.1.4.06 CRYOMODULE ACCEPTANCE TEST #6** |  | 2012-12-03 | 2013-02-11 |  |  |  |  |  |  |  |  |  |  |  |  |  |  |  |  |  |  |  |  |  |  |  |  |  |  |  |  |  |  |  |  |  |  |  |  |  |  |  |
| 131406000 |  | Acceptance Test Cryomodule #6 | 33d | 2012-12-03 A | 2013-02-11 A | 1317035, 131404010, 131302006b, 131302006 | 100% | 2013-01-02 | 2013-02-19 | ELEC TECH [120 h]; MECH ENG [80 h]; MECH TECH [160 h]; SUPPLIES & MATERIALS; SCIENTIST [40 h]; COMP SCIENT [40 h]; SR STAFF [40 h]; ELEC ENG [240 h] | 51,676.49 | 46,352.4 | 0 | 50243.29 | HOGAN J | 1 | 1 | H | JOHN H | 08-050 | 09-017 | 09-032 | 09-032 | 10-031 | 10-064 |  | 10-066 | 11-012 | 11-051 | 12-018 | 12-028F | 10-023 | 131406000 | 11-003 | XX |  |  |  |  |  |  |  |  |  |
|  | 07 | **1.3.1.4.07 CRYOMODULE ACCEPTANCE TEST #7** |  | 2012-05-01 | 2012-06-27 |  |  |  |  |  |  |  |  |  |  |  |  |  |  |  |  |  |  |  |  |  |  |  |  |  |  |  |  |  |  |  |  |  |  |  |  |  |  |  |
| 131407000a |  | Acceptance Test Cryomodule #7 FY13 | 39d | 2012-05-01 A | 2012-06-27 A | 131407000 | 100% | 2012-05-01 | 2012-06-26 | MECH ENG [35.29 h]; SCIENTIST [17.65 h]; SR STAFF [17.65 h]; COMP SCIENT [17.65 h]; ELEC ENG [105.88 h]; ELEC TECH [52.94 h]; MECH TECH [70.59 h]; SUPPLIES & MATERIALS | 22,241.38 | 19,817.59 | 0 | 22873.6927 | HOGAN J | 1 | 1 | H | JOHN H | 08-050 | 09-017 |  |  | 10-031 | 10-064 |  | 10-066 | 11-012 | 11-051 | 12-018 | 12-028F |  |  | 11-003 |  | 12-053 |  |  |  |  |  |  |  |  |
| 131407000 |  | Acceptance Test Cryomodule #7 FY12 | 40d | 2012-05-01 A | 2012-06-27 A | 131406000 FS-90d, 131302007 | 100% |  |  | SR STAFF [22.35 h]; ELEC ENG [134.12 h]; ELEC TECH [67.06 h]; COMP SCIENT [22.35 h]; MECH ENG [44.71 h]; MECH TECH [89.41 h]; SUPPLIES & MATERIALS; SCIENTIST [22.35 h] | 28,076.84 | 25,101.61 | 0 | 28076.8311 | HOGAN J | 1 | 1 | H | JOHN H | 08-050 | 09-017 |  |  | 10-031 | 10-064 |  | 10-066 | 11-012 | 11-051 | 12-018 | 12-028F |  | 131407000 | 11-003 |  | 12-053 | OPC A |  |  |  |  |  |  |  |
|  | 08 | **1.3.1.4.08 CRYOMODULE ACCEPTANCE TEST #8** |  | 2013-02-12 | 2013-03-11 |  |  |  |  |  |  |  |  |  |  |  |  |  |  |  |  |  |  |  |  |  |  |  |  |  |  |  |  |  |  |  |  |  |  |  |  |  |  |  |
| 131408000 |  | Acceptance Test Cryomodule #8 | 33d | 2013-02-12 A | 2013-03-11 A | 131302008, 131406000, 131407000a | 100% | 2013-03-12 | 2013-04-25 | SUPPLIES & MATERIALS; SCIENTIST [52.86 h]; ELEC TECH [158.58 h]; SR STAFF [52.86 h]; ELEC ENG [317.16 h]; COMP SCIENT [52.86 h]; MECH TECH [211.43 h]; MECH ENG [105.72 h] | 68,513.53 | 61,253.51 | 0 | 68513.5299 | HOGAN J | 1 | 1 | H | JOHN H | 08-050 | 09-017 | 09-032 | 09-032 | 10-031 | 10-064 |  | 10-066 | 11-012 | 11-051 | 12-018 | 12-028F | 10-023 | 131408000 | 11-003 |  |  | OPC A | 13-003 |  |  |  |  |  |  |
|  | 09 | **1.3.1.4.09 CRYOMODULE ACCEPTANCE TEST #9** |  | 2013-03-11 | 2013-04-16 |  |  |  |  |  |  |  |  |  |  |  |  |  |  |  |  |  |  |  |  |  |  |  |  |  |  |  |  |  |  |  |  |  |  |  |  |  |  |  |
| 131409000 |  | Acceptance Test Cryomodule #9 | 34d | 2013-03-11 A | 2013-04-16 A | 131302009a, 131408000 FS+9d | 100% | 2013-05-13 | 2013-06-28 | SR STAFF [52.86 h]; ELEC ENG [317.16 h]; ELEC TECH [158.58 h]; COMP SCIENT [52.86 h]; MECH ENG [105.72 h]; MECH TECH [211.43 h]; SUPPLIES & MATERIALS; SCIENTIST [52.86 h] | 68,513.53 | 61,253.51 | 0 | 68513.5299 | HOGAN J | 1 | 1 | H | JOHN H | 08-050 | 09-017 |  |  | 10-031 | 10-064 |  | 10-066 | 11-012 | 11-051 | 12-018 | 12-028F |  | 131409000 | 11-003 |  |  | OPC A | 13-003 | 10-027 |  |  |  |  |  |
|  | 10 | **1.3.1.4.10 CRYOMODULE ACCEPTANCE TEST #10** |  | 2013-04-20 | 2013-06-18 |  |  |  |  |  |  |  |  |  |  |  |  |  |  |  |  |  |  |  |  |  |  |  |  |  |  |  |  |  |  |  |  |  |  |  |  |  |  |  |
| 131410000 |  | Acceptance Test Cryomodule #10 | 35d | 2013-04-20 A | 2013-06-18 A | 131409000 FS+1d, 131302010 | 100% | 2013-05-20 | 2013-07-09 | ELEC TECH [158.58 h]; COMP SCIENT [52.86 h]; MECH ENG [105.72 h]; MECH TECH [211.43 h]; SUPPLIES & MATERIALS; SCIENTIST [52.86 h]; SR STAFF [52.86 h]; ELEC ENG [317.16 h] | 68,513.53 | 61,253.51 | 0 | 68513.5299 | HOGAN J | 1 | 1 | H | JOHN H | 08-050 | 09-017 | 09-032 | 09-032 | 10-031 | 10-064 |  | 10-066 | 11-012 | 11-051 | 12-018 | 12-028F | 10-023 | 131410000 | 11-003 |  |  | OPC A | 13-003 | 10-027 |  |  |  |  |  |
|  | 5 | **1.3.1.5 CRYOMODULE INSTALLATION AND TEST** |  | 2011-08-02 | 2013-08-30 |  |  |  |  |  |  |  |  |  |  |  |  |  |  |  |  |  |  |  |  |  |  |  |  |  |  |  |  |  |  |  |  |  |  |  |  |  |  |  |
| 1315000 |  | Re-Baseline Actuals Adjustment | 1d | 2013-08-30 A | 2013-08-30 A |  | 100% | 2013-09-03 | 2013-09-03 | PROCUREMENT>$50K 69 NO ESCALATION | 58,387.38 |  |  | 58387.38 |  |  |  |  |  |  |  |  |  |  |  |  |  |  |  |  |  |  |  |  |  |  |  |  |  | 0 | 58387.38 | 5838738 | 100 | ADJ |

Notes:
- 131406000: Explanation: 4 weeks to recomissiom cmtf

| ID | WBS | Activity | Duration | Start | Finish | Predecessors | Complete | Planned start | Planned finish | Resources | Cost | Actual cost | Calculated Remaining Total Cost | MONTHLY EV COST | RESP - Responsibility | STRT%COMP for CM EVM | FNSH%COMP for CM EVM | EVMS Reporting Codes | CAM RESPONSIBLE | CR 08-050 | Installation | CR 10-031 | CR 10-064 | CR 10-065 | CR 10-066 | CR 11-012 | CR 12-001 | Specification | CR 12-018 | CR 12-028 | OPC Allison | CR 13-003 | MARCH!!! |
| --- | --- | --- | --- | --- | --- | --- | --- | --- | --- | --- | --- | --- | --- | --- | --- | --- | --- | --- | --- | --- | --- | --- | --- | --- | --- | --- | --- | --- | --- | --- | --- | --- | --- |
|  | 01 | **1.3.1.5.01 CRYOMODULE #1 INSTALLATION AND TEST** |  | 2011-08-02 | 2011-09-29 |  |  |  |  |  |  |  |  |  |  |  |  |  |  |  |  |  |  |  |  |  |  |  |  |  |  |  |  |
| 131501000 |  | Installaton Cryomodule #1 | 6d | 2011-08-02 A | 2011-08-09 A | 3A-20M FS-80d, 131401000, 4A-01M, 13436020 | 100% |  |  | MECH TECH [40 h] | 1,722.8 | 1,722.8 | 0 | 1722.8 | HOGAN J | 1 | 1 | H | JOHN H | 08-050 | Install | 10-031 | 10-064 | 10-065 | 10-066 |  |  |  |  |  |  |  |  |
| 131501005 |  | In-Tunnel Checkout and Commisioning Cryomodule #1 | 28d | 2011-08-21 A | 2011-09-29 A | 13436025, 132112081M, 131501000, 13213010, 132121061M | 100% | 2011-08-22 | 2011-09-29 | SUPPLIES & MATERIALS; SCIENTIST [40 h]; SR STAFF [40 h]; ELEC TECH [120 h]; COMP SCIENT [40 h]; ELEC ENG [240 h]; MECH ENG [80 h]; MECH TECH [160 h] | 48,691.5 | 43,532 | 0 | 48691.5 | HOGAN J | 1 | 1 | H | JOHN H |  |  |  | 10-064 |  | 10-066 |  |  |  |  |  |  |  |  |
|  | 02 | **1.3.1.5.02 CRYOMODULE #2 INSTALLATION AND TEST** |  | 2011-09-16 | 2011-09-28 |  |  |  |  |  |  |  |  |  |  |  |  |  |  |  |  |  |  |  |  |  |  |  |  |  |  |  |  |
| 131502000 |  | Installaton Cryomodule #2 | 5d | 2011-09-16 A | 2011-09-22 A | 131402000, 131501000, 13436030 | 100% |  |  | MECH TECH [40 h] | 1,722.8 | 1,722.8 | 0 | 1722.8 | HOGAN J | 1 | 1 | H | JOHN H | 08-050 | Install | 10-031 | 10-064 | 10-065 | 10-066 | 11-012 |  |  |  |  |  |  |  |
| 131502005 |  | In-Tunnel Checkout and Commisioning Cryomodule #2 | 4d | 2011-09-23 A | 2011-09-28 A | 131501005 FS-5d, 13436035, 132121062M, 131502000, 132112082M, 13213010a | 100% |  |  | MECH ENG [66.67 h]; SUPPLIES & MATERIALS; MECH TECH [133.33 h]; SR STAFF [33.33 h]; SCIENTIST [33.33 h]; ELEC ENG [200 h]; ELEC TECH [100 h]; COMP SCIENT [33.33 h] | 40,575.52 | 36,275.94 | 0 | 40575.5245 | HOGAN J | 1 | 1 | H | JOHN H |  |  |  | 10-064 |  | 10-066 |  | 12-001 |  |  |  |  |  |  |
| 131502005a |  | In-Tunnel Checkout and Commisioning Cryomodule #2 FY12 | 4d | 2011-09-23 A | 2011-09-28 A | 131502005 | 100% |  |  | MECH TECH [26.67 h]; SR STAFF [6.67 h]; SCIENTIST [6.67 h]; ELEC ENG [40 h]; ELEC TECH [20 h]; COMP SCIENT [6.67 h]; MECH ENG [13.33 h]; SUPPLIES & MATERIALS | 8,143.41 | 7,256.06 | 0 | 8374.6285 | HOGAN J | 1 | 1 | H | JOHN H | 08-050 |  | 10-031 | 10-064 |  | 10-066 |  | 12-001 |  |  |  |  |  |  |
|  | 03 | **1.3.1.5.03 CRYOMODULE #3 INSTALLATION AND TEST** |  | 2012-10-15 | 2012-12-15 |  |  |  |  |  |  |  |  |  |  |  |  |  |  |  |  |  |  |  |  |  |  |  |  |  |  |  |  |
| 131503000 |  | Installaton Cryomodule #3 5th | 43d | 2012-10-15 A | 2012-12-15 A | 2-02M, 13436055, 131505000, 131403000, 132121065M, 132112085M FS-35d, 131502005a | 100% | 2012-10-15 | 2012-12-14 | MECH TECH [221.71 h] | 10,167.62 | 10,167.62 | 0 | 10167.6206 | HOGAN J | 1 | 1 | H | JOHN H | 08-050 | Install | 10-031 | 10-064 |  | 10-066 |  |  | 131503000 | 12-018 | 12-028 | OPC A | 13-003 |  |
|  | 04 | **1.3.1.5.04 CRYOMODULE #4 INSTALLATION AND TEST** |  | 2012-05-21 | 2012-07-30 |  |  |  |  |  |  |  |  |  |  |  |  |  |  |  |  |  |  |  |  |  |  |  |  |  |  |  |  |
| 131504000 |  | Installaton Cryomodule #4 3rd | 19d | 2012-05-21 A | 2012-06-18 A | 132112083M, 131404000, 132121063M, 131404010 FS+9d | 100% |  |  | MECH TECH [40 h] | 1,777.6 | 1,777.6 | 0 | 1777.6 | HOGAN J | 1 | 1 | H | JOHN H | 08-050 | Install | 10-031 | 10-064 |  | 10-066 |  |  | 131504000 | 12-018 | 12-028F |  |  |  |
| 131504005 |  | In-Tunnel Checkout and Commisioning Cryomodule #4 3rd | 23d | 2012-06-28 A | 2012-07-30 A | 131504000, 13213010b | 100% |  |  | SCIENTIST [40 h]; ELEC ENG [240 h]; COMP SCIENT [16 h]; ELEC TECH [120 h]; MECH ENG [80 h]; SR STAFF [40 h]; MECH TECH [160 h]; SUPPLIES & MATERIALS | 48,668.41 | 43,344.32 | 0 | 48668.41 | HOGAN J | 1 | 1 | H | JOHN H |  |  |  | 10-064 |  | 10-066 |  |  | 131504005 | 12-018 | 12-028 |  |  |  |
|  | 05 | **1.3.1.5.05 CRYOMODULE #5 INSTALLATION AND TEST** |  | 2012-05-18 | 2012-06-29 |  |  |  |  |  |  |  |  |  |  |  |  |  |  |  |  |  |  |  |  |  |  |  |  |  |  |  |  |
| 131505000 |  | Installaton Cryomodule #5 4th | 29d | 2012-05-18 A | 2012-06-29 A | 132113115 FS-85d, 131504000 FS-10d, 132121064M, 13436050 FS-20d, 132112084M, 131405000 | 100% |  |  | MECH TECH [40 h] | 1,777.6 | 1,777.6 | 0 | 1777.6 | HOGAN J | 1 | 1 | H | JOHN H | 08-050 | Install | 10-031 | 10-064 |  | 10-066 |  |  | 131505000 | 12-018 | 12-028F |  |  |  |
| 131505005 |  | In-Tunnel Checkout and Commisioning Cryomodule #5 4th | 10d | 2012-06-18 A | 2012-06-29 A | 13213010c, 131505000 | 100% |  |  | ELEC TECH [120 h]; SR STAFF [40 h]; COMP SCIENT [16 h]; SUPPLIES & MATERIALS; MECH ENG [80 h]; MECH TECH [160 h]; SCIENTIST [40 h]; ELEC ENG [240 h] | 48,668.41 | 43,344.32 | 0 | 48668.41 | HOGAN J | 1 | 1 | H | JOHN H |  |  |  | 10-064 |  | 10-066 |  |  | 131505005 | 12-018 | 12-028 |  |  |  |
|  | 06 | **1.3.1.5.06 CRYOMODULE #6 INSTALLATION AND TEST** |  | 2013-03-11 | 2013-03-25 |  |  |  |  |  |  |  |  |  |  |  |  |  |  |  |  |  |  |  |  |  |  |  |  |  |  |  |  |
| 131506000 |  | Installaton Cryomodule #6 | 30d | 2013-03-11 A | 2013-03-25 A | 132112086M FS-15d, 131503000, 131505005, 131406000, 132121066M | 100% | 2013-04-16 | 2013-05-28 | MECH TECH [221.71 h] | 10,167.62 | 10,167.62 | 0 | 10167.6206 | HOGAN J | 1 | 1 | H | JOHN H | 08-050 | Install | 10-031 | 10-064 |  | 10-066 |  |  | 131506000 | 12-018 | 12-028 | OPC A | 13-003 | XX |
|  | 07 | **1.3.1.5.07 CRYOMODULE #7 INSTALLATION AND TEST** |  | 2012-10-22 | 2012-12-17 |  |  |  |  |  |  |  |  |  |  |  |  |  |  |  |  |  |  |  |  |  |  |  |  |  |  |  |  |
| 131507000 |  | Installaton Cryomodule #7 | 43d | 2012-10-22 A | 2012-12-17 A | 132121067M FS-40d, 132112087M FS-65d, 131407000a | 100% | 2012-10-22 | 2012-12-21 | MECH TECH [221.71 h] | 10,167.62 | 10,167.62 | 0 | 10167.6206 | HOGAN J | 1 | 1 | H | JOHN H | 08-050 | Install | 10-031 | 10-064 |  | 10-066 |  |  | 131507000 | 12-018 | 12-028 | OPC A | 13-003 |  |
|  | 08 | **1.3.1.5.08 CRYOMODULE #8 INSTALLATION AND TEST** |  | 2013-03-11 | 2013-04-15 |  |  |  |  |  |  |  |  |  |  |  |  |  |  |  |  |  |  |  |  |  |  |  |  |  |  |  |  |
| 131508000 |  | Installaton Cryomodule #8 | 13d | 2013-03-11 A | 2013-04-15 A | 132112088M FS-60d, 132121068M, 131507000, 131408000 FS-2d | 100% | 2013-06-13 | 2013-07-01 | MECH TECH [221.71 h] | 10,167.62 | 10,167.62 | 0 | 10167.6206 | HOGAN J | 1 | 1 | H | JOHN H | 08-050 | Install | 10-031 | 10-064 |  | 10-066 |  |  | 131508000 | 12-018 | 12-028 | OPC A | 13-003 |  |
|  | 09 | **1.3.1.5.09 CRYOMODULE #9 INSTALLATION AND TEST** |  | 2013-04-16 | 2013-05-10 |  |  |  |  |  |  |  |  |  |  |  |  |  |  |  |  |  |  |  |  |  |  |  |  |  |  |  |  |
| 131509000 |  | Installaton Cryomodule #9 | 13d | 2013-04-16 A | 2013-05-10 A | 132121069M, 132112089M FS-60d, 131508000, 131409000 FS-12d | 100% | 2013-05-16 | 2013-06-04 | MECH TECH [221.71 h] | 10,167.62 | 10,167.62 | 0 | 10167.6206 | HOGAN J | 1 | 1 | H | JOHN H | 08-050 | Install | 10-031 | 10-064 |  | 10-066 |  |  | 131509000 | 12-018 | 12-028 | OPC A | 13-003 |  |
|  | 10 | **1.3.1.5.10 CRYOMODULE #10 INSTALLATION AND TEST** |  | 2013-06-03 | 2013-06-14 |  |  |  |  |  |  |  |  |  |  |  |  |  |  |  |  |  |  |  |  |  |  |  |  |  |  |  |  |
| 131510000 |  | Installaton Cryomodule #10 | 12d | 2013-06-03 A | 2013-06-14 A | 132112090M FS-60d, 132122030M, 131509000, 132121070M, 131410000 | 100% | 2013-07-19 | 2013-08-05 | MECH TECH [221.71 h] | 10,167.62 | 10,167.62 | 0 | 10167.6206 | HOGAN J | 1 | 1 | H | JOHN H | 08-050 | Install | 10-031 | 10-064 |  | 10-066 |  |  | 131510000 | 12-018 | 12-028 | OPC A | 13-003 |  |

| ID | WBS | Activity | Type | Duration | Start | Finish | Predecessors | Complete | Planned start | Planned finish | Constraint | Calendar | Resources | Cost | Actual cost | Calculated Remaining Total Cost | MONTHLY EV COST | RESP - Responsibility | STRT%COMP for CM EVM | FNSH%COMP for CM EVM | EVMS Reporting Codes | CAM RESPONSIBLE | CR 11-045 | Remaining Material Cost Based on % Compl | Claimed Material Cost Based on % Complet | Initial Claimed Material Calc | Claimed Material Divider | ReBaseline Actuals Adjustment | CR 10-064 | CR 11-003 | CR 11-012 | CR 11-051 | CR 12-018 | CR 08-050 | CR 10-027 | Specification | Milestone Level | CR 09-023 | Advance Purchase Plan > 500K | 12 GEV MAJOR PROCUREMENT CATAGORY | CR 10-001 | CR 12-028 | CR 10-028 | CR 10-066 | CR 11-015 | LOE Divider | LOE Multiplier | CR 08-016 | CR 09-012 | CR 10-031 | Phil Dev | CR 13-009 | CR 11-001 | CR 12-001 | LOE % Pre Calc | LOE % | Profile change | CR 08-052 | Original Activity ID Rebaseline | PRIOR MONTH EV COST | BOE Labor | CR 13-015 | Post Rebaseline |
| --- | --- | --- | --- | --- | --- | --- | --- | --- | --- | --- | --- | --- | --- | --- | --- | --- | --- | --- | --- | --- | --- | --- | --- | --- | --- | --- | --- | --- | --- | --- | --- | --- | --- | --- | --- | --- | --- | --- | --- | --- | --- | --- | --- | --- | --- | --- | --- | --- | --- | --- | --- | --- | --- | --- | --- | --- | --- | --- | --- | --- | --- | --- | --- |
|  | 6 | **1.3.1.6 MICROPHONICS** |  |  | 2011-06-01 | 2013-08-30 |  |  |  |  |  |  |  |  |  |  |  |  |  |  |  |  |  |  |  |  |  |  |  |  |  |  |  |  |  |  |  |  |  |  |  |  |  |  |  |  |  |  |  |  |  |  |  |  |  |  |  |  |  |  |  |  |  |
| 1316005 |  | Initial studies in accelerator tunnel |  | 22d | 2011-06-01 A | 2011-06-30 A | 9-110M FS+162d | 100% |  |  |  |  | ELEC ENG [548 h]; ELEC TECH [738 h]; MECH ENG [457.5 h]; MECH TECH [577.57 h] | 124,999.57 | 124,999.57 | 0 | 124999.5649 | HOGAN J | 1 | 1 | H | JOHN H | 11-045 |  |  |  |  |  |  |  |  |  |  |  |  |  |  |  |  |  |  |  |  |  |  |  |  |  |  |  |  |  |  |  |  |  |  |  |  |  |  |  |  |
| 1316010 |  | Analysis and mitigation development |  | 43d | 2011-07-01 A | 2011-08-31 A | 1316005 FS-5d | 100% |  |  |  |  | ELEC TECH [292.26 h]; MECH ENG [643.86 h]; MECH TECH [290.23 h]; SCIENTIST [182.67 h]; MECH DES [267.78 h]; ELEC ENG [457 h] | 125,000.2 | 125,000.2 | 0 | 125000.1918 | HOGAN J | 1 | 1 | H | JOHN H | 11-045 |  |  |  |  |  |  |  |  |  |  |  |  |  |  |  |  |  |  |  |  |  |  |  |  |  |  |  |  |  |  |  |  |  |  |  |  |  |  |  |  |
| 1316015 |  | Re-Baseline Actuals Adjustment |  | 1d | 2013-08-30 A | 2013-08-30 A |  | 100% | 2013-09-03 | 2013-09-03 |  |  | PROCUREMENT>$50K 69 NO ESCALATION | 12,446.48 |  |  | 12446.48 |  |  |  |  |  |  | 0 | 12446.48 | 1244648 | 100 | ADJ |  |  |  |  |  |  |  |  |  |  |  |  |  |  |  |  |  |  |  |  |  |  |  |  |  |  |  |  |  |  |  |  |  |  |  |
|  | 7 | **1.3.1.7 TEDF INTERFACE** |  |  | 2010-08-09 | 2012-11-30 |  |  |  |  |  |  |  |  |  |  |  |  |  |  |  |  |  |  |  |  |  |  |  |  |  |  |  |  |  |  |  |  |  |  |  |  |  |  |  |  |  |  |  |  |  |  |  |  |  |  |  |  |  |  |  |  |  |
| 1317000 |  | TEDF Summer Down 2010 |  | 23d | 2010-08-09 A | 2010-09-09 A | 9-100M FS+211d, 1311122010 FS-35d | 100% |  |  |  |  |  |  |  |  | 0 | HOGAN J | 1 | 1 | Z | JOHN H | 11-045 |  |  |  |  |  | 10-064 | 11-003 | 11-012 | 11-051 |  |  |  |  |  |  |  |  |  |  |  |  |  |  |  |  |  |  |  |  |  |  |  |  |  |  |  |  |  |  |  |
| 1317005 |  | TEDF Winter Down 2010 |  | 14d | 2010-12-20 A | 2011-01-14 A | 9-110M FS+54d, 1311122030, 1312103050 FS-60d | 100% |  |  |  |  |  |  |  |  | 0 | HOGAN J | 1 | 1 | Z | JOHN H | 11-045 |  |  |  |  |  | 10-064 | 11-003 | 11-012 | 11-051 | 12-018F |  |  |  |  |  |  |  |  |  |  |  |  |  |  |  |  |  |  |  |  |  |  |  |  |  |  |  |  |  |  |
| 1317010 |  | TEDF Summer Down 2011 |  | 20d | 2011-07-01 A | 2011-07-29 A | 9-110M FS+184d, 1312405000 FS-43d, 1311122087, 1312108030 FS-52d | 100% |  |  |  |  |  |  |  |  | 0 | HOGAN J | 1 | 1 | Z | JOHN H | 11-045 |  |  |  |  |  | 10-064 | 11-003 | 11-012 | 11-051 | 12-018F |  |  |  |  |  |  |  |  |  |  |  |  |  |  |  |  |  |  |  |  |  |  |  |  |  |  |  |  |  |  |
| 1317020 |  | Transition - Planning and Coordination |  | 131d | 2011-10-03 A | 2012-04-16 A | 9-120M | 100% |  |  |  |  |  |  |  |  | 0 | HOGAN J | 1 | 1 | Z | JOHN H | 11-045 |  |  |  |  |  | 10-064 |  |  | 11-051 | 12-018F | 08-050 | 10-027 |  |  |  |  |  |  |  |  |  |  |  |  |  |  |  |  |  |  |  |  |  |  |  |  |  |  |  |  |
| 1317015 |  | TEDF Winter Down 2011 |  | 36d | 2011-12-03 A | 2012-02-01 A | 9-120M FS+53d | 100% | 2011-12-05 | 2012-02-01 |  |  |  |  |  |  | 0 | HOGAN J | 1 | 1 | Z | JOHN H | 11-045 |  |  |  |  |  | 10-064 |  |  |  |  |  |  |  |  |  |  |  |  |  |  |  |  |  |  |  |  |  |  |  |  |  |  |  |  |  |  |  |  |  |  |
| 1317025 |  | Transition - Cryomodule Work Center |  | 37d | 2012-06-29 A | 2012-08-20 A | 1317020 FS+50d | 100% |  |  | mandatory start 2012-06-18 |  |  |  |  |  | 0 | HOGAN J | 1 | 1 | Z | JOHN H | 11-045 |  |  |  |  |  | 10-064 |  |  | 11-051 | 12-018 | 08-050 | 10-027 |  |  |  |  |  |  |  |  |  |  |  |  |  |  |  |  |  |  |  |  |  |  |  |  |  |  |  |  |
| 1317035 |  | CMTF Down - TL Renovation |  | 108d | 2012-06-29 A | 2012-11-30 A | 1317025 FS-35d | 100% |  |  |  |  |  |  |  |  | 0 | HOGAN J | 1 | 1 | Z | JOHN H | 11-045 |  |  |  |  |  | 10-064 |  |  | 11-051 | 12-018 | 08-050 | 10-027 | 1317035 |  |  |  |  |  |  |  |  |  |  |  |  |  |  |  |  |  |  |  |  |  |  |  |  |  |  |  |
|  | 2 | **1.3.2 POWER SYSTEMS** |  |  | 2009-01-22 | 2014-09-30 |  |  |  |  |  |  |  |  |  |  |  |  |  |  |  |  |  |  |  |  |  |  |  |  |  |  |  |  |  |  |  |  |  |  |  |  |  |  |  |  |  |  |  |  |  |  |  |  |  |  |  |  |  |  |  |  |  |
|  | 1 | **1.3.2.1 RF** |  |  | 2009-04-21 | 2013-12-13 |  |  |  |  |  |  |  |  |  |  |  |  |  |  |  |  |  |  |  |  |  |  |  |  |  |  |  |  |  |  |  |  |  |  |  |  |  |  |  |  |  |  |  |  |  |  |  |  |  |  |  |  |  |  |  |  |  |
|  | 1 | **1.3.2.1.1 POWER** |  |  | 2009-04-21 | 2013-09-30 |  |  |  |  |  |  |  |  |  |  |  |  |  |  |  |  |  |  |  |  |  |  |  |  |  |  |  |  |  |  |  |  |  |  |  |  |  |  |  |  |  |  |  |  |  |  |  |  |  |  |  |  |  |  |  |  |  |
|  | 1 | **1.3.2.1.1.1 KLYSTRONS** |  |  | 2009-04-21 | 2013-09-30 |  |  |  |  |  |  |  |  |  |  |  |  |  |  |  |  |  |  |  |  |  |  |  |  |  |  |  |  |  |  |  |  |  |  |  |  |  |  |  |  |  |  |  |  |  |  |  |  |  |  |  |  |  |  |  |  |  |
| 132111025M |  | Klystron Contract Awarded (KLYSTRONS) | milestone | 0d | 2009-04-21 A | 2009-04-21 A | 1212111120, 9-090M FS+134d | 100% | 2009-05-01 | 2009-05-01 |  |  |  |  |  |  | 0 | NELSON R | 1 | 1 | M | BILL M |  |  |  |  |  |  |  |  |  |  |  |  |  |  | 6 | 09-023 |  |  |  |  |  |  |  |  |  |  |  |  |  |  |  |  |  |  |  |  |  |  |  |  |  |
| 132111030 |  | Vend Fab Dsgn Period (Klystrons) |  | 84d | 2009-04-21 A | 2009-08-18 A | 32-01M, 132111025M | 100% |  |  |  |  | PROCUREMENT>$50K 69 NO ESCALATION; PROCUREMENT<$50K 60 NO ESCALATION | 98,456 |  | 0 | 98456 | NELSON R | 1 | 1 | P | BILL M |  | 0 | 98456 | 9845600 | 100 |  |  |  |  |  |  |  |  |  |  | 09-023 | APP | 32111 | 10-001A | 12-028F |  |  |  |  |  |  |  |  |  |  |  |  |  |  |  |  |  |  |  |  |  |
| 132111035 |  | Klystron Dsgn Review & Approval for Production (Klystrons) |  | 6d | 2009-08-11 A | 2009-08-18 A | 132111030 | 100% |  |  |  |  | ELEC ENG [88 h]; ELEC DES [80 h] | 9,330.64 | 9,330.64 | 0 | 9330.64 | NELSON R | 1 | 1 | H | BILL M |  |  |  |  |  |  |  |  |  |  |  |  |  |  |  | 09-023 |  |  |  | 12-028F |  |  |  |  |  |  |  |  |  |  |  |  |  |  |  |  |  |  |  |  |  |
| 132111040 |  | Vend Manufacture First article Klystron (Order and Recieve Parts) |  | 149d | 2009-08-18 A | 2010-03-29 A | 132111035 | 100% |  |  |  |  | PROCUREMENT>$50K 69 NO ESCALATION; PROCUREMENT<$50K 60 NO ESCALATION | 147,684 |  | 0 | 147684 | NELSON R | 1 | 1 | P | BILL M |  | 0 | 147684 | 14768400 | 100 |  | 10-064 |  |  |  | 12-018F |  |  |  |  | 09-023 |  |  | 10-001A |  | 10-028 | 10-066 | 11-015 |  |  |  |  |  |  |  |  |  |  |  |  |  |  |  |  |  |  |
| 132111040A |  | Vend Manufacture First article Klystron (First Article Testing) |  | 257d | 2009-08-18 A | 2010-08-30 A | 132111040 FS-58d | 100% |  |  |  |  | PROCUREMENT>$50K 69 NO ESCALATION; PROCUREMENT<$50K 60 NO ESCALATION | 196,912 |  | 0 | 196912 | NELSON R | 1 | 1 | D | BILL M |  | 0 | 196912 | 19691200 | 100 |  | 10-064 |  |  |  | 12-018F |  |  |  |  | 09-023 |  |  | 10-001A |  | 10-028 | 10-066 | 11-015 |  |  |  |  |  |  |  |  |  |  |  |  |  |  |  |  |  |  |
| 132111040B |  | Vend Manufacture First article Klystron (Delivery of FA Report) |  | 356d | 2009-08-18 A | 2011-01-28 A | 132111040A FS-156d | 100% |  |  |  |  | PROCUREMENT>$50K 69 NO ESCALATION; PROCUREMENT<$50K 60 NO ESCALATION | 49,228 |  | 0 | 49228 | NELSON R | 1 | 1 | P | BILL M |  | 0 | 49228 | 4922800 | 100 |  | 10-064 |  |  |  | 12-018F |  |  |  |  | 09-023 |  |  | 10-001A |  | 10-028 | 10-066 | 11-015 |  |  |  |  |  |  |  |  |  |  |  |  |  |  |  |  |  |  |
| 132111042 |  | Vend Manufacture First article Klystron (Klystrons) LABOR/EXPS FY09 |  | 252d | 2009-08-18 A | 2010-08-23 A | 132111035, 132111040B FS-208d | 100% |  |  |  |  | SUPPLIES & MATERIALS | 805.8 |  | 0 | 805.8 | NELSON R | 1 | 1 | H | BILL M |  |  |  |  |  |  | 10-064 |  |  |  | 12-018F |  |  |  |  | 09-023 |  |  | 10-001B |  | 10-028 | 10-066 | 11-015 |  |  |  |  |  |  |  |  |  |  |  |  |  |  |  |  |  |  |
| 132111042b |  | Vend Manufacture First article Klystron (Klystrons) LABOR/EXPS FY10 |  | 266d | 2009-09-30 A | 2010-10-25 A | 132111042 FS-400d | 100% |  |  |  |  | SUPPLIES & MATERIALS | 4,859.1 |  | 0 | 4859.103591 | NELSON R | 1 | 1 | H | BILL M |  |  |  |  |  |  | 10-064 |  |  |  | 12-018F |  |  |  |  |  |  |  | 10-001B |  | 10-028 | 10-066 | 11-015 |  |  |  |  |  |  |  |  |  |  |  |  |  |  |  |  |  |  |
| 132111911LOE |  | Proj Admin (2011) ongoing (Klystrons) |  | 248d | 2009-10-01 A | 2010-09-30 A | 9-100M | 100% |  |  |  |  | SR STAFF [880 h] | 93,385.6 | 93,385.6 | 0 | 93385.6 | NELSON R | 1 | 1 | E | BILL M |  |  |  |  |  |  |  |  |  |  |  |  |  |  |  |  |  |  |  |  |  |  |  | 100 | 100 |  |  |  |  |  |  |  |  |  |  |  |  |  |  |  |  |
| 132111049M |  | Start of Klystron Production | milestone | 0d | 2010-09-01 A | 2010-09-01 A | 132111049 FS-30d | 100% | 2010-10-19 | 2010-10-19 |  |  |  |  |  |  | 0 | NELSON R | 1 | 1 | M | BILL M |  |  |  |  |  |  | 10-064 |  |  |  | 12-018F |  |  |  | 6 | 09-023 |  |  |  |  | 10-028 | 10-066 | 11-015 |  |  |  |  |  |  |  |  |  |  |  |  |  |  |  |  |  |  |
| 132111050 |  | Vend Klystron Production (Klystron 1&2) |  | 148d | 2010-09-01 A | 2011-04-11 A | 132111049M FS-10d, 2-01M FS-30d | 100% |  |  |  |  | PROCUREMENT<$50K 60 NO ESCALATION; PROCUREMENT>$50K 69 NO ESCALATION | 73,514 |  | 0 | 73514 | NELSON R | 1 | 1 | D | BILL M |  | 0 | 73514 | 7351400 | 100 |  |  |  |  |  |  |  |  |  |  | 09-023 | APP | 32111 | 10-001A | 12-028F | 10-028 |  | 11-015 |  |  | 08-016 | 09-012 |  |  |  |  |  |  |  |  |  |  |  |  |  |  |
| 132111050A |  | Vend Klystron Production (Klystrons 3-6) |  | 178d | 2010-09-01 A | 2011-05-23 A | 132111050 FS-107d, 132111049M, 2-01M FS-30d | 100% |  |  |  |  | PROCUREMENT>$50K 69 NO ESCALATION | 147,028.03 |  | 0 | 147028.03 | NELSON R | 1 | 1 | D | BILL M |  | 0 | 147028.03 | 14702803 | 100 |  |  |  |  |  |  |  |  |  |  | 09-023 | APP | 32111 | 10-001A | 12-028F | 10-028 |  | 11-015 |  |  | 08-016 |  |  |  |  |  |  |  |  |  |  |  |  |  |  |  |
| 132111050B |  | Vend Klystron Production (Klystrons 7-10) |  | 205d | 2010-09-01 A | 2011-06-30 A | 132111049M, 2-01M FS-30d, 132111050A FS-124d | 100% |  |  |  |  | PROCUREMENT>$50K 69 NO ESCALATION | 147,028.03 |  | 0 | 147028.03 | NELSON R | 1 | 1 | D | BILL M |  | 0 | 147028.03 | 14702803 | 100 |  |  |  |  |  |  |  |  |  |  | 09-023 | APP | 32111 | 10-001A | 12-028F | 10-028 |  | 11-015 |  |  | 08-016 |  |  |  |  |  |  |  |  |  |  |  |  |  |  |  |
| 132111050C |  | Vend Klystron Production (Klystrons 11-14) |  | 207d | 2010-09-01 A | 2011-07-05 A | 132111049M, 2-01M FS-30d, 132111050B FS-144d | 100% |  |  |  |  | PROCUREMENT>$50K 69 NO ESCALATION | 147,028.03 |  | 0 | 147028.03 | NELSON R | 1 | 1 | D | BILL M |  | 0 | 147028.03 | 14702803 | 100 |  |  |  |  |  |  |  |  |  |  | 09-023 | APP | 32111 | 10-001A | 12-028F | 10-028 |  | 11-015 |  |  | 08-016 |  |  |  |  |  |  |  |  |  |  |  |  |  |  |  |
| 132111050D |  | Vend Klystron Production (Klystrons 15&16) |  | 222d | 2010-09-01 A | 2011-07-26 A | 2-01M FS-30d, 132111050C FS-163d, 132111049M | 100% |  |  |  |  | PROCUREMENT>$50K 69 NO ESCALATION | 73,514 |  | 0 | 73514 | NELSON R | 1 | 1 | D | BILL M |  | 0 | 73514 | 7351400 | 100 |  |  |  |  |  |  |  |  |  |  | 09-023 | APP | 32111 | 10-001A | 12-028F | 10-028 |  | 11-015 |  |  | 08-016 |  |  |  |  |  |  |  |  |  |  |  |  |  |  |  |
| 132111050F |  | Vend Klystron Production (Klystrons 17-19) |  | 240d | 2010-09-01 A | 2011-08-20 A | 132111049M, 2-01M FS-30d, 132111050D FS-186d | 100% | 2010-09-01 | 2011-08-19 |  |  | PROCUREMENT>$50K 69 NO ESCALATION | 110,271.03 |  | 0 | 110271.03 | NELSON R | 1 | 1 | D | BILL M |  | 0 | 110271.03 | 11027103 | 100 |  |  |  |  |  |  |  |  |  |  | 09-023 | APP | 32111 | 10-001A | 12-028F | 10-028 |  | 11-015 |  |  | 08-016 |  |  |  |  |  |  |  |  |  |  |  |  |  |  |  |
| 132111050G |  | Vend Klystron Production (Klystrons 20-24) |  | 257d | 2010-09-01 A | 2011-09-14 A | 132111049M, 2-01M FS-30d, 132111050F FS-207d | 100% |  |  |  |  | PROCUREMENT>$50K 69 NO ESCALATION | 183,785.05 |  | 0 | 183785.05 | NELSON R | 1 | 1 | D | BILL M |  | 0 | 183785.05 | 18378505 | 100 |  |  |  |  |  |  |  |  |  |  | 09-023 | APP | 32111 | 10-001A | 12-028F | 10-028 |  | 11-015 |  |  | 08-016 |  |  |  |  |  |  |  |  |  |  |  |  |  |  |  |
| 132111050H |  | Vend Klystron Production (Klystrons 25-30) |  | 285d | 2010-09-01 A | 2011-10-24 A | 132111049M, 2-01M FS-30d, 132111050G FS-228d | 100% |  |  |  |  | PROCUREMENT>$50K 69 NO ESCALATION | 220,541.96 |  | 0 | 220541.96 | NELSON R | 1 | 1 | D | BILL M |  | 0 | 220541.96 | 22054196 | 100 |  |  |  |  |  |  |  |  |  |  | 09-023 | APP | 32111 | 10-001A | 12-028F | 10-028 |  | 11-015 |  |  | 08-016 |  |  |  |  |  |  |  |  |  |  |  |  |  |  |  |
| 132111050J |  | Vend Klystron Production (Klystrons 37-42) |  | 336d | 2010-09-01 A | 2012-01-16 A | 132111049M, 2-01M FS-30d, 132111050i FS-271d | 100% | 2010-09-01 | 2012-01-13 |  |  | PROCUREMENT>$50K 69 NO ESCALATION | 220,541.96 |  | 0 | 220541.96 | NELSON R | 1 | 1 | D | BILL M |  | 0 | 220541.96 | 22054196 | 100 |  | 10-064 |  |  |  | 12-018F |  |  |  |  | 09-023 | APP | 32111 | 10-001A |  | 10-028 | 10-066 | 11-015 |  |  | 08-016 |  | 10-031 |  |  |  |  |  |  |  |  |  |  |  |  |  |
| 132111050K |  | Vend Klystron Production (Klystrons 43-48) |  | 369d | 2010-09-01 A | 2012-03-02 A | 2-01M FS-30d, 132111049M, 132111050J FS-314d | 100% |  |  |  |  | PROCUREMENT>$50K 69 NO ESCALATION | 220,541.96 |  | 0 | 220541.96 | NELSON R | 1 | 1 | D | BILL M |  | 0 | 220541.96 | 22054196 | 100 |  |  |  |  |  |  |  |  |  |  | 09-023 | APP | 32111 | 10-001A | 12-028F | 10-028 |  | 11-015 |  |  | 08-016 |  |  |  |  |  |  |  |  |  |  |  |  |  |  |  |
| 132111050L |  | Vend Klystron Production (Klystrons 49-54) |  | 379d | 2010-09-01 A | 2012-03-17 A | 132111050K FS-314d, 132111049M, 2-01M FS-30d | 100% | 2010-09-01 | 2012-03-16 |  |  | PROCUREMENT>$50K 69 NO ESCALATION | 220,541.96 |  | 0 | 220541.96 | NELSON R | 1 | 1 | D | BILL M |  | 0 | 220541.96 | 22054196 | 100 |  |  |  |  |  |  |  |  |  |  | 09-023 | APP | 32111 | 10-001A | 12-028F | 10-028 |  | 11-015 |  |  | 08-016 |  |  |  |  |  |  |  |  |  |  |  |  |  |  |  |
| 132111050N |  | Vend Klystron Production (Klystrons 55-60) |  | 380d | 2010-09-01 A | 2012-03-19 A | 2-01M FS-30d, 132111050L FS-335d, 132111049M | 100% |  |  |  |  | PROCUREMENT>$50K 69 NO ESCALATION | 220,541.96 |  | 0 | 220541.96 | NELSON R | 1 | 1 | D | BILL M |  | 0 | 220541.96 | 22054196 | 100 |  |  |  |  |  |  |  |  |  |  | 09-023 | APP | 32111 | 10-001A | 12-028F | 10-028 |  | 11-015 |  |  | 08-016 |  |  |  |  |  |  |  |  |  |  |  |  |  |  |  |
| 132111050P |  | Vend Klystron Production (Klystrons 67-72) |  | 419d | 2010-09-01 A | 2012-05-14 A | 132111049M, 132111050o FS-392d, 2-01M FS-30d | 100% | 2010-09-01 | 2012-05-11 |  |  | PROCUREMENT>$50K 69 NO ESCALATION | 220,541.96 |  | 0 | 220541.96 | NELSON R | 1 | 1 | D | BILL M |  | 0 | 220541.96 | 22054196 | 100 |  |  |  |  |  |  |  |  |  |  | 09-023 | APP | 32111 | 10-001A | 12-028F | 10-028 |  | 11-015 |  |  | 08-016 |  |  |  |  |  |  |  |  |  |  |  |  |  |  |  |
| 132111050Q |  | Vend Klystron Production (Klystrons 73-78) |  | 438d | 2010-09-01 A | 2012-06-11 A | 132111049M, 2-01M FS-30d, 132111050P FS-392d | 100% |  |  |  |  | PROCUREMENT>$50K 69 NO ESCALATION | 220,541.96 |  | 0 | 220541.96 | NELSON R | 1 | 1 | D | BILL M |  | 0 | 220541.96 | 22054196 | 100 |  |  |  |  |  |  |  |  |  |  | 09-023 | APP | 32111 | 10-001A | 12-028F | 10-028 |  | 11-015 |  |  | 08-016 |  |  |  |  |  |  |  |  |  |  |  |  |  |  |  |
| 132111050R |  | Vend Klystron Production (Klystrons 79-83) |  | 483d | 2010-09-01 A | 2012-08-13 A | 2-01M FS-30d, 132111049M | 100% |  |  |  |  | PROCUREMENT>$50K 69 NO ESCALATION | 183,785.19 |  | 0 | 183785.19 | NELSON R | 1 | 1 | D | BILL M |  | 0 | 183785.19 | 18378519 | 100 |  |  |  |  |  |  |  |  |  |  | 09-023 | APP | 32111 | 10-001A | 12-028F | 10-028 |  | 11-015 |  |  | 08-016 |  |  | MP |  |  |  |  |  |  |  |  |  |  |  |  |
| 132111050i |  | Vend Klystron Production (Klystrons 31-36) |  | 308d | 2010-09-01 A | 2011-11-28 A | 132111049M, 2-01M FS-30d, 132111050H FS-249d | 100% |  |  |  |  | PROCUREMENT>$50K 69 NO ESCALATION | 220,541.96 |  | 0 | 220541.96 | NELSON R | 1 | 1 | D | BILL M |  | 0 | 220541.96 | 22054196 | 100 |  |  |  |  |  |  |  |  |  |  | 09-023 | APP | 32111 | 10-001A | 12-028F | 10-028 |  | 11-015 |  |  | 08-016 |  |  |  |  |  |  |  |  |  |  |  |  |  |  |  |
| 132111050o |  | Vend Klystron Production (Klystrons 61-66) |  | 419d | 2010-09-01 A | 2012-05-14 A | 2-01M FS-30d, 132111049M | 100% | 2010-09-01 | 2012-05-11 |  |  | PROCUREMENT>$50K 69 NO ESCALATION | 220,541.96 |  | 0 | 220541.96 | NELSON R | 1 | 1 | D | BILL M |  | 0 | 220541.96 | 22054196 | 100 |  | 10-064 |  |  |  | 12-018F |  |  |  |  | 09-023 | APP | 32111 | 10-001A | 12-028F | 10-028 | 10-066 | 11-015 |  |  | 08-016 |  | 10-031 |  | 13-009F |  |  |  |  |  |  |  |  |  |  |  |
| 132111052 |  | Vend Klystron Production LABOR/EXP FY10 |  | 482.89d | 2010-09-01 A | 2012-08-13 A | 132111049M | 100% |  |  |  |  | ELEC ENG [1.97 h]; SUPPLIES & MATERIALS | 1,531.98 | 136.43 | 0 | 1526.1619 | NELSON R | 1 | 1 | H | BILL M |  |  |  |  |  |  |  |  |  |  |  |  |  |  |  | 09-023 | APP | 32111 |  | 12-028F | 10-028 |  |  |  |  | 08-016 |  |  |  |  | 11-001 |  |  |  |  |  |  |  |  |  |  |
| 132111052a |  | Vend Klystron Production LABOR/EXP FY11 |  | 483d | 2010-09-01 A | 2012-08-13 A | 132111052 FS-419d | 100% |  |  |  |  | ELEC ENG [8.72 h]; SUPPLIES & MATERIALS | 6,981.72 | 603.9 | 0 | 6974.093299 | NELSON R | 1 | 1 | H | BILL M |  |  |  |  |  |  |  |  |  |  |  |  |  |  |  | 09-023 | APP | 32111 |  | 12-028F | 10-028 |  |  |  |  | 08-016 |  |  |  |  | 11-001 | 12-001 |  |  |  |  |  |  |  |  |  |
| 132111052ab |  | Vend Klystron Production LABOR/EXP FY12 |  | 483d | 2010-09-01 A | 2012-08-13 A | 132111052a FS-160d | 100% | 2010-09-01 | 2012-08-14 |  |  | SUPPLIES & MATERIALS; ELEC ENG [5.31 h] | 4,374.87 | 367.74 | 0 | 4381.8036 | NELSON R | 1 | 1 | H | BILL M |  |  |  |  |  |  |  |  |  |  |  |  |  |  |  | 09-023 | APP | 32111 |  | 12-028F | 10-028 |  |  |  |  | 08-016 | 09-012 |  |  |  | 11-001 | 12-001 |  |  |  |  |  |  |  |  |  |
| 132111045 |  | Test First article Klystron (Klystrons) |  | 92d | 2010-10-01 A | 2011-02-21 A | 132111040B FS-53d, 132111040 FS-85d, 132111042b FS-32d, 132111040A FS-85d | 100% | 2010-10-01 | 2011-02-18 |  |  | ELEC DES [80 h]; ELEC ENG [40 h]; TRAVEL; SUPPLIES & MATERIALS; ELEC TECH [40 h] | 14,592.1 | 8,362 | 0 | 14334.106569 | NELSON R | 1 | 1 | H | BILL M |  |  |  |  |  |  | 10-064 |  |  |  | 12-018F |  |  |  |  | 09-023 |  |  |  |  | 10-028 | 10-066 | 11-015 |  |  |  |  |  |  |  |  |  |  |  |  |  |  |  |  |  |  |
| 132111912LOE |  | Proj Admin (2012) ongoing (Klystrons) |  | 248d | 2010-10-01 A | 2011-09-30 A | 132111911LOE | 100% |  |  |  |  | SR STAFF [880 h] | 96,368.8 | 96,368.8 | 0 | 96368.8 | NELSON R | 1 | 1 | E | BILL M |  |  |  |  |  |  |  |  |  |  |  |  |  |  |  |  |  |  |  |  |  |  |  | 100 | 100 |  |  |  |  |  |  |  | 8.46774193 | 91.53225806 |  |  |  |  |  |  |  |
| 132111049 |  | Grant Approval for Klystron Production, (Klystrons) |  | 61d | 2010-11-15 A | 2011-02-21 A | 9-100M FS+60d, 132111040A FS-5d, 132111040B FS-29d, 132111042b FS-5d, 132111045 FS-15d | 100% | 2010-11-15 | 2011-02-18 |  |  | ELEC ENG [12 h] | 820.56 | 820.56 | 0 | 795.24 | NELSON R | 1 | 1 | H | BILL M |  |  |  |  |  |  | 10-064 |  |  |  | 12-018F |  |  |  |  | 09-023 |  |  |  |  | 10-028 | 10-066 | 11-015 |  |  |  |  |  |  |  |  |  |  |  |  |  |  |  |  |  |  |
| 132111060 |  | Release Prcrmnt Package, Driver Amplifer (Klystrons) |  | 48d | 2010-12-13 A | 2011-02-28 A | 9-110M FS+40d, 132111049 FS-20d | 100% |  |  |  |  | ELEC ENG [4 h] | 273.52 | 273.52 | 0 | 273.52 | NELSON R | 1 | 1 | H | BILL M |  |  |  |  |  |  |  |  |  |  |  |  |  |  |  |  |  |  |  | 12-028F | 10-028 |  |  |  |  |  |  |  |  |  |  |  |  |  |  |  |  |  |  |  |  |
| 132111068 |  | Bid Driver Amplifer Prcrmnt (Klystrons) |  | 15d | 2011-01-31 A | 2011-02-21 A | 132111065 | 100% | 2011-01-31 | 2011-02-18 |  |  | ELEC ENG [4 h] | 273.52 | 273.52 | 0 | 273.52 | NELSON R | 1 | 1 | H | BILL M |  |  |  |  |  |  |  |  |  |  |  |  |  |  |  |  |  |  |  | 12-028F | 10-028 |  |  |  |  |  |  |  |  |  |  |  |  |  |  |  |  |  |  |  |  |
| 132111065 |  | Receive & Evaluate Driver Amplifer Proposals (Klystrons) |  | 15d | 2011-02-07 A | 2011-02-28 A | 132111060 FS+4d | 100% |  |  |  |  | ELEC ENG [20 h] | 1,367.6 | 1,367.6 | 0 | 1367.6 | NELSON R | 1 | 1 | H | BILL M |  |  |  |  |  |  |  |  |  |  |  |  |  |  |  |  |  |  |  | 12-028F | 10-028 |  |  |  |  |  |  |  |  |  |  |  |  |  |  |  |  |  |  |  |  |
| 132111075 |  | Dsgn Review for Driver Amplifer (Klystrons) |  | 10d | 2011-02-14 A | 2011-02-28 A | 132111070 FS-20d | 100% |  |  |  |  | ELEC ENG [8 h] | 547.04 | 547.04 | 0 | 547.04 | NELSON R | 1 | 1 | H | BILL M |  |  |  |  |  |  |  |  |  |  |  |  |  |  |  |  |  |  |  | 12-028F | 10-028 |  |  |  |  |  |  |  |  |  |  |  |  |  |  |  |  |  |  |  |  |
| 132111069M |  | Award Driver Amplifer Prcrmnt (KLYSTRONS) | milestone | 0d | 2011-02-21 A | 2011-02-21 A | 132111068 FS+2d, 9-110M | 100% | 2011-03-25 | 2011-03-25 |  |  |  |  |  |  | 0 | NELSON R | 1 | 1 | M | BILL M |  |  |  |  |  |  |  |  |  |  |  |  |  |  | 6 |  |  |  |  | 12-028F | 10-028 |  |  |  |  |  |  |  |  |  |  |  |  |  | C |  |  |  |  |  |  |
| 132111070 |  | Vend Fab Driver Amplifer 1st Article (Klystrons) |  | 21d | 2011-02-28 A | 2011-03-28 A | 132111069M | 100% |  |  |  |  | PROCUREMENT<$50K 60 | 30,155.51 |  | 0 | 30155.51 | NELSON R | 1 | 1 | D | BILL M |  | 0 | 30155.51 | 3015551 | 100 |  |  |  |  |  |  |  |  |  |  |  | APP |  |  | 12-028F | 10-028 |  |  |  |  |  |  |  |  |  |  |  |  |  |  |  |  |  |  |  |  |
| 132111080 |  | Vendor Fab Lot 1 Driver Amplifers (Klystrons) Labor FY11 |  | 118d | 2011-03-01 A | 2011-08-15 A | 132111075 FS-20d | 100% |  |  |  |  | ELEC ENG [7.26 h]; ELEC TECH [36.31 h] | 2,049.42 | 2,049.42 | 0 | 2049.4175 | NELSON R | 1 | 1 | D | BILL M |  |  |  |  |  |  |  |  |  |  |  |  |  |  |  |  | APP |  |  | 12-028F | 10-028 |  |  |  |  | 08-016 | 09-012 |  |  |  |  | 12-001 |  |  |  |  |  |  |  |  |  |
| 132111080a |  | Vendor Fab Lot 1 Driver Amplifers (Klystrons) Labor FY12 |  | 118d | 2011-03-01 A | 2011-08-15 A | 132111080 | 100% |  |  |  |  | ELEC TECH [3.69 h]; ELEC ENG [0.74 h] | 208.42 | 208.42 | 0 | 215.0541 | NELSON R | 1 | 1 | D | BILL M |  |  |  |  |  |  |  |  |  |  |  |  |  |  |  |  | APP |  |  | 12-028F | 10-028 |  |  |  |  | 08-016 | 09-012 |  |  |  |  | 12-001 |  |  |  |  |  |  |  |  |  |
| 132111080b |  | Vendor Fab Lot 1 Driver Amplifers (Klystrons) Procurement |  | 118d | 2011-03-01 A | 2011-08-15 A | 132111075 | 100% |  |  |  |  | PROCUREMENT<$50K 60 NO ESCALATION FY12 | 28,345.91 |  | 0 | 28345.91 | NELSON R | 1 | 1 | D | BILL M |  | 0 | 28345.91 | 2834591 | 100 |  |  |  |  |  |  |  |  |  |  |  | APP |  |  | 12-028F | 10-028 |  |  |  |  | 08-016 | 09-012 |  |  |  |  | 12-001 |  |  |  |  |  |  |  |  |  |
| 132111115 |  | Vendor Fab Lot 2 of Driver Amplifers (Klystrons) |  | 32d | 2011-06-30 A | 2011-08-15 A | 132111080 FS-30d, 132111080b, 132111080a FS-30d | 100% |  |  |  |  | PROCUREMENT<$50K 60 | 61,573.91 |  | 0 | 61573.91 | NELSON R | 1 | 1 | D | BILL M |  | 0 | 61573.91 | 6157391 | 100 |  |  |  |  |  |  |  |  |  |  |  | APP |  |  | 12-028F | 10-028 |  |  |  |  |  |  |  |  |  |  |  |  |  |  |  |  |  |  |  |  |
| 132111055 |  | Receive & Test Production Klystrons FY11 |  | 280.85d | 2011-08-01 A | 2012-09-14 A | 132111050 | 100% |  |  |  |  | ELEC TECH [193.21 h]; ELEC ENG [41.4 h] | 11,392.23 | 11,392.23 | 0 | 11094.5237 | NELSON R | 1 | 1 | U | BILL M |  |  |  |  |  |  |  |  |  |  |  |  |  |  |  | 09-023 |  |  |  | 12-028F | 10-028 |  | 11-015 |  |  |  |  |  |  |  |  | 12-001 |  |  |  |  |  |  |  |  |  |
| 132111055a |  | Receive & Test Production Klystrons FY12 |  | 280.85d | 2011-08-01 A | 2012-09-14 A | 132111055 FS-245d | 100% |  |  |  |  | ELEC TECH [366.79 h]; ELEC ENG [78.6 h] | 21,627.46 | 21,627.46 | 0 | 21732.4587 | NELSON R | 1 | 1 | U | BILL M |  |  |  |  |  |  |  |  |  |  |  |  |  |  |  | 09-023 |  |  |  | 12-028F | 10-028 |  | 11-015 |  |  |  |  |  |  |  |  | 12-001 |  |  |  |  |  |  |  |  |  |
| 132111115M |  | Driver amplfier Prcrmnt Comp (KLYSTRONS) | milestone | 0d | 2011-08-15 A | 2011-08-15 A | 132111115 | 100% | 2011-09-22 | 2011-09-22 |  |  |  |  |  |  | 0 | NELSON R | 1 | 1 | M | BILL M |  |  |  |  |  |  |  |  |  |  |  |  |  |  | 6 |  |  |  |  | 12-028F | 10-028 |  |  |  |  |  |  |  |  |  |  |  |  |  |  |  |  |  |  |  |  |
| 132111913LOE |  | Proj Admin (2013) ongoing (Klystrons) |  | 247d | 2011-10-03 A | 2012-09-28 A | 132111912LOE | 100% |  |  |  |  | SR STAFF [600 h] | 67,800 | 67,800 | 0 | 67800 | NELSON R | 1 | 1 | E | BILL M |  |  |  |  |  |  |  |  |  |  |  |  |  |  |  |  |  |  |  |  |  |  |  | 100 | 100 |  |  |  |  |  |  |  | 7.69230769 | 92.3076923 |  |  |  |  |  |  |  |
| 132111057M |  | Production Klystrons Received and Tested | milestone | 0d | 2012-09-14 A | 2012-09-14 A | 132111050o, 132111050J, 132111052ab, 132111050N, 132111050R, 132111055a, 132111050Q | 100% | 2012-10-12 | 2012-10-12 |  |  |  |  |  |  | 0 | NELSON R | 1 | 1 | M | BILL M |  |  |  |  |  |  |  |  |  |  |  |  |  |  |  | 09-023 |  |  |  | 12-028F | 10-028 |  | 11-015 |  |  |  |  |  |  |  |  |  |  |  |  |  |  |  |  |  |  |
| 132111914LOE |  | Proj Admin (2014) ongoing (Klystrons) |  | 248d | 2012-10-01 A | 2013-08-30 A | 132111913LOE | 100% | 2012-10-01 | 2013-09-30 |  |  | SR STAFF [183.87 h] | 21,439.24 | 21,439.24 | 3950.408 | 21439.242 | NELSON R | 1 | 1 | E | BILL M |  |  |  |  |  |  |  |  |  |  |  |  |  |  |  |  |  |  |  |  |  |  |  | 100 | 100 |  |  |  |  |  |  |  | 8.06451612 | 91.93548387 |  | 08-052 |  |  |  |  |  |
| 132111950 |  | Re-Baseline Actuals Adjustment |  | 1d | 2013-08-30 A | 2013-08-30 A |  | 100% | 2013-09-03 | 2013-09-03 |  |  | PROCUREMENT>$50K 69 NO ESCALATION | -36,764.16 |  |  |  |  |  |  |  |  |  |  |  |  | 100 | ADJ |  |  |  |  |  |  |  |  |  |  |  |  |  |  |  |  |  |  |  |  |  |  |  |  |  |  |  |  |  |  |  |  |  |  |  |
| 232111914LOE |  | Proj Admin ongoing (Klystrons) |  | 20d | 2013-09-03 A | 2013-09-30 A | 9-130M FS+228d | 100% | 2013-10-01 | 2013-10-28 |  | 8/5 M-F w/JLAB Holidays ReBaseline | SR STAFF [16.13 h] | 1,940.76 | 1,880.76 |  | 0 | NELSON R | 1 | 1 | E | BILL M |  |  |  |  |  |  |  |  |  |  |  |  |  |  |  |  |  |  |  |  |  |  |  |  |  |  |  |  |  |  |  |  |  |  |  | 08-052 | 232111914LOE | 1880.758 | EJ | 13-015 | PR |

Notes:
- 132111040A: Explanation: Changed EVMS code from P to D based on Invoicing / 5/27/10

| ID | WBS | Activity | Type | Duration | Start | Finish | Predecessors | Complete | Planned start | Planned finish | Resources | Cost | Actual cost | MONTHLY EV COST | RESP - Responsibility | STRT%COMP for CM EVM | FNSH%COMP for CM EVM | Milestone Level | CR 08-009 | EVMS Reporting Codes | CAM RESPONSIBLE | CR 08-049 | CR 08-052 | Installation | CR 10-028 | CR 10-031 | CR 10-064 | CR 10-066 | CR 12-028 | CR 11-015 | CR 12-018 | MARCH!!! | CR 11-043 | Calculated Remaining Total Cost | 12 GEV MAJOR PROCUREMENT CATAGORY | CR 10-036 | Remaining Material Cost Based on % Compl | Claimed Material Cost Based on % Complet | Initial Claimed Material Calc | Claimed Material Divider | CR 13-009 | ReBaseline Actuals Adjustment |
| --- | --- | --- | --- | --- | --- | --- | --- | --- | --- | --- | --- | --- | --- | --- | --- | --- | --- | --- | --- | --- | --- | --- | --- | --- | --- | --- | --- | --- | --- | --- | --- | --- | --- | --- | --- | --- | --- | --- | --- | --- | --- | --- |
|  | 2 | **1.3.2.1.1.2 DC POWER** |  |  | 2009-05-22 | 2013-08-30 |  |  |  |  |  |  |  |  |  |  |  |  |  |  |  |  |  |  |  |  |  |  |  |  |  |  |  |  |  |  |  |  |  |  |  |  |
| 132112081M |  | First Zone Installed/Tested (DC Power) | milestone | 0d | 2011-07-23 A | 2011-07-23 A | 1321122100, 132121061M FS+5d, 4A-03M | 100% | 2011-08-23 | 2011-08-23 |  |  |  | 0 | NELSON R | 1 | 1 | 6 | 08-009 | M | BILL M | 08-049 | 08-052 | Install | 10-028 | 10-031 | 10-064 | 10-066 |  |  |  |  |  |  |  |  |  |  |  |  |  |  |
| 132112082M |  | Second Zone Installed/Tested (DC Power) | milestone | 0d | 2011-09-23 A | 2011-09-23 A | 132121062M FS+5d, 1321122105 | 100% | 2011-10-18 | 2011-10-18 |  |  |  | 0 | NELSON R | 1 | 1 | 6 | 08-009 | M | BILL M | 08-049 | 08-052 | Install | 10-028 | 10-031 | 10-064 | 10-066 |  |  |  |  |  |  |  |  |  |  |  |  |  |  |
| 132112083M |  | Third Zone Installed/Tested (DC Power) | milestone | 0d | 2012-02-28 A | 2012-02-28 A | 1321122110, 132121063M FS+5d | 100% | 2012-03-28 | 2012-03-28 |  |  |  | 0 | NELSON R | 1 | 1 | 6 | 08-009 | M | BILL M | 08-049 | 08-052 | Install | 10-028 | 10-031 | 10-064 | 10-066 | 12-028F |  |  |  |  |  |  |  |  |  |  |  |  |  |
| 132112084M |  | Fourth Zone Installed/Tested (DC Power) | milestone | 0d | 2012-04-16 A | 2012-04-16 A | 132112083M, 132111050J, 132121064M FS+5d, 1321122115a | 100% | 2012-05-01 | 2012-05-01 |  |  |  | 0 | NELSON R | 1 | 1 | 6 | 08-009 | M | BILL M | 08-049 | 08-052 | Install | 10-028 | 10-031 | 10-064 | 10-066 |  | 11-015 | 12-018F |  |  |  |  |  |  |  |  |  |  |  |
| 132112085M |  | Fifth Zone Installed/Tested (DC Power) | milestone | 0d | 2013-01-31 A | 2013-01-31 A | 1321122120a, 1321122180, 132121065M FS+5d | 100% | 2013-03-01 | 2013-03-01 |  |  |  | 0 | NELSON R | 1 | 1 | 6 | 08-009 | M | BILL M | 08-049 | 08-052 | Install | 10-028 | 10-031 | 10-064 | 10-066 | 12-028 |  | 12-018F | XX |  |  |  |  |  |  |  |  |  |  |
| 132112086M |  | Sixth Zone Installed/Tested (DC Power) | milestone | 0d | 2013-04-15 A | 2013-04-15 A | 1321122125, 1321122185 | 100% | 2013-05-15 | 2013-05-15 |  |  |  | 0 | NELSON R | 1 | 1 | 6 | 08-009 | M | BILL M | 08-049 | 08-052 | Install | 10-028 | 10-031 | 10-064 | 10-066 | 12-028 |  | 12-018F | XX | 11-043 |  |  |  |  |  |  |  |  |  |
| 132112087M |  | Seventh Zone Installed/Tested (DC Power) | milestone | 0d | 2013-05-24 A | 2013-05-24 A | 132111050o, 132121067M FS-40d, 132112086M FS-50d, 1321122130, 1321122190 | 100% | 2013-06-17 | 2013-06-17 |  |  |  | 0 | NELSON R | 1 | 1 | 6 | 08-009 | M | BILL M | 08-049 | 08-052 | Install | 10-028 | 10-031 | 10-064 | 10-066 | 12-028 |  | 12-018F | XX | 11-043 |  |  |  |  |  |  |  |  |  |
| 132112088M |  | Eighth Zone Installed/Tested (DC Power) | milestone | 0d | 2013-06-14 A | 2013-06-14 A | 1321122195, 1321122135 | 100% | 2013-07-08 | 2013-07-08 |  |  |  | 0 | NELSON R | 1 | 1 | 6 | 08-009 | M | BILL M | 08-049 | 08-052 | Install | 10-028 | 10-031 | 10-064 | 10-066 | 12-028 |  | 12-018F | XX | 11-043 |  |  |  |  |  |  |  |  |  |
| 132112089M |  | Ninth Zone Installed/Tested (DC Power) | milestone | 0d | 2013-07-29 A | 2013-07-29 A | 1321122140, 1321122200 | 100% | 2013-08-20 | 2013-08-20 |  |  |  | 0 | NELSON R | 1 | 1 | 6 | 08-009 | M | BILL M | 08-049 | 08-052 | Install | 10-028 | 10-031 | 10-064 | 10-066 | 12-028 |  | 12-018F |  | 11-043 |  |  |  |  |  |  |  |  |  |
| 132112090M |  | Tenth Zone Installed/Tested (DC Power) | milestone | 0d | 2013-08-18 A | 2013-08-18 A | 1321121035, 1321122145, 1321122015a, 1321122030a, 1321122205, 1321122047LOE | 100% | 2013-09-18 | 2013-09-18 |  |  |  | 0 | NELSON R | 1 | 1 | 6 | 08-009 | M | BILL M | 08-049 | 08-052 | Install | 10-028 | 10-031 | 10-064 | 10-066 | 12-028 |  | 12-018F |  | 11-043 |  |  |  |  |  |  |  |  |  |
|  | 1 | **1.3.2.1.1.2.1 High Voltage Power Supply** |  |  | 2009-05-22 | 2013-08-30 |  |  |  |  |  |  |  |  |  |  |  |  |  |  |  |  |  |  |  |  |  |  |  |  |  |  |  |  |  |  |  |  |  |  |  |  |
| 1321121000 |  | Bid HVPS |  | 46d | 2009-05-22 A | 2009-07-28 A | 9-090M FS+175d | 100% |  |  | ELEC ENG [40 h] | 2,569.2 | 2,569.2 | 2569.2 | NELSON R | 1 | 1 |  |  | H | BILL M | 08-049 |  |  |  |  |  |  |  |  |  |  |  | 0 |  |  |  |  |  |  |  |  |
| 1321121005 |  | Evaluate HVPS |  | 102d | 2009-07-27 A | 2009-12-21 A | 1321121000 | 100% | 2009-07-27 | 2009-12-18 | ELEC ENG [80 h] | 5,226.4 | 5,226.4 | 5138.4 | NELSON R | 1 | 1 |  |  | H | BILL M | 08-049 |  |  |  |  |  |  |  |  |  |  |  | 0 |  |  |  |  |  |  |  |  |
| 1321121010 |  | Award HVPS Lot 1 (3) |  | 18d | 2009-12-21 A | 2010-01-22 A | 9-100M, 1321121005 | 100% | 2009-12-28 | 2010-01-22 | ELEC ENG [20 h] | 1,325.4 | 1,325.4 | 1325.4 | NELSON R | 1 | 1 |  |  | H | BILL M | 08-049 |  |  |  |  |  |  |  |  |  |  |  | 0 |  |  |  |  |  |  |  |  |
| 1321121015 |  | Fabricate HVPS Lot 1 (3) Original Expenses |  | 145d | 2010-01-04 A | 2010-07-29 A | 1321121010 | 100% |  |  | TRAVEL | 5,324.09 |  | 5324.08805 | NELSON R | 1 | 1 |  |  | H | BILL M | 08-049 |  |  | 10-028 | 10-031 | 10-064 | 10-066 |  |  |  |  |  | 0 | 32112A | 10-036 |  |  |  |  |  |  |
| 1321121020 |  | Vend Fab HVPS Peg Point #1 Design Review |  | 82d | 2010-01-04 A | 2010-04-29 A | 9-100M FS+59d | 100% |  |  | PROCUREMENT>$50K 69 NO ESCALATION; PROCUREMENT<$50K 60 NO ESCALATION | 71,950 |  | 71950 | NELSON R | 1 | 1 |  |  | P | BILL M | 08-049 |  |  | 10-028 | 10-031 | 10-064 | 10-066 |  |  |  |  |  | 0 | 32112A | 10-036 | 0 | 71950 | 7195000 | 100 |  |  |
| 1321121025 |  | Vend Fab HVPS Peg Point #2 Special Non Stock parts for 10 Systems |  | 326d | 2010-01-04 A | 2011-04-25 A | 1321121020 FS-61d | 100% |  |  | PROCUREMENT>$50K 69 NO ESCALATION | 170,550 |  | 170550 | NELSON R | 1 | 1 |  |  | D | BILL M | 08-049 |  |  | 10-028 | 10-031 | 10-064 | 10-066 |  |  |  |  |  | 0 | 32112A | 10-036 | 0 | 170550 | 17055000 | 100 |  |  |
| 1321121030 |  | Vend Fab HVPS Peg Point #3 Test 1st Article |  | 272d | 2010-01-04 A | 2011-02-07 A | 1321121025 FS-146d | 100% |  |  | PROCUREMENT>$50K 69 NO ESCALATION | 33,265 |  | 33265 | NELSON R | 1 | 1 |  |  | P | BILL M | 08-049 |  |  | 10-028 | 10-031 | 10-064 | 10-066 |  |  |  |  |  | 0 | 32112A | 10-036 | 0 | 33265 | 3326500 | 100 |  |  |
| 1321121035 |  | Vend Fab HVPS Peg Point #4 Ship and Accept 1st Article |  | 305d | 2010-01-04 A | 2011-03-25 A | 1321121030 FS-230d | 100% |  |  | PROCUREMENT>$50K 69 NO ESCALATION | 117,633 |  | 117633 | NELSON R | 1 | 1 |  |  | P | BILL M | 08-049 |  |  | 10-028 | 10-031 | 10-064 | 10-066 |  |  |  |  |  | 0 | 32112A | 10-036 | 0 | 117633 | 11763300 | 100 |  |  |
| 1321121040 |  | Vend Fab HVPS Peg Point #5 Ship and Accept unit #2 |  | 305d | 2010-01-04 A | 2011-03-25 A | 1321121035 FS-247d | 100% |  |  | PROCUREMENT>$50K 69 NO ESCALATION | 82,633 |  | 82633 | NELSON R | 1 | 1 |  |  | P | BILL M |  |  |  | 10-028 | 10-031 | 10-064 | 10-066 |  |  |  |  |  | 0 | 32112A | 10-036 | 0 | 82633 | 8263300 | 100 |  |  |
| 1321121045 |  | Vend Fab HVPS Peg Point #6 Ship and Accept unit #3 |  | 332d | 2010-01-04 A | 2011-05-03 A | 1321121040 FS-286d | 100% |  |  | PROCUREMENT>$50K 69 NO ESCALATION | 83,133 |  | 83133 | NELSON R | 1 | 1 |  |  | P | BILL M |  |  |  | 10-028 | 10-031 | 10-064 | 10-066 | 12-028F |  | 12-018F |  | 11-043 | 0 | 32112A | 10-036 | 0 | 83133 | 8313300 | 100 | 13-009F |  |
| 1321121050 |  | Vend Fab HVPS Peg Point #7 Ship and Accept unit #4 |  | 350d | 2010-01-04 A | 2011-05-29 A | 1321121045 FS-309d | 100% | 2010-01-04 | 2011-05-27 | PROCUREMENT>$50K 69 NO ESCALATION | 82,633 |  | 82633 | NELSON R | 1 | 1 |  |  | P | BILL M |  |  |  | 10-028 | 10-031 | 10-064 | 10-066 | 12-028F |  | 12-018F |  | 11-043 | 0 | 32112A | 10-036 | 0 | 82633 | 8263300 | 100 | 13-009F |  |
| 1321121055 |  | Vend Fab HVPS Peg Point #8 Ship and Accept unit #5 |  | 380d | 2010-01-04 A | 2011-07-12 A | 1321121050 FS-330d | 100% |  |  | PROCUREMENT>$50K 69 NO ESCALATION | 82,633 |  | 82633 | NELSON R | 1 | 1 |  |  | P | BILL M |  |  |  | 10-028 | 10-031 | 10-064 | 10-066 | 12-028F |  | 12-018F |  | 11-043 | 0 | 32112A | 10-036 | 0 | 82633 | 8263300 | 100 | 13-009F |  |
| 1321121060 |  | Vend Fab HVPS Peg Point #9 Ship and Accept unit #6 |  | 412d | 2010-01-04 A | 2011-08-26 A | 1321121055 FS-351d | 100% | 2010-01-04 | 2011-08-25 | PROCUREMENT>$50K 69 NO ESCALATION | 82,633 |  | 82633 | NELSON R | 1 | 1 |  |  | P | BILL M |  |  |  | 10-028 | 10-031 | 10-064 | 10-066 | 12-028F |  | 12-018F |  | 11-043 | 0 | 32112A | 10-036 | 0 | 82633 | 8263300 | 100 | 13-009F |  |
| 1321121065 |  | Vend Fab HVPS Peg Point #10 Ship and Accept unit #7 |  | 440d | 2010-01-04 A | 2011-10-05 A | 1321121060 FS-373d | 100% |  |  | PROCUREMENT>$50K 69 NO ESCALATION | 82,633 |  | 82633 | NELSON R | 1 | 1 |  |  | P | BILL M |  |  |  | 10-028 | 10-031 | 10-064 | 10-066 | 12-028F |  | 12-018F |  | 11-043 | 0 | 32112A | 10-036 | 0 | 82633 | 8263300 | 100 | 13-009F |  |
| 1321121070 |  | Vend Fab HVPS Peg Point #11 Ship and Accept unit #8 |  | 463d | 2010-01-04 A | 2011-11-07 A | 1321121065 FS-393d | 100% |  |  | PROCUREMENT>$50K 69 NO ESCALATION | 82,633 |  | 82633 | NELSON R | 1 | 1 |  |  | P | BILL M |  |  |  | 10-028 | 10-031 | 10-064 | 10-066 | 12-028F |  | 12-018F |  | 11-043 | 0 | 32112A | 10-036 | 0 | 82633 | 8263300 | 100 | 13-009F |  |
| 1321121075 |  | Vend Fab HVPS Peg Point #12 Ship and Accept unit #9 |  | 491d | 2010-01-04 A | 2011-12-19 A | 1321121070 FS-416d | 100% |  |  | PROCUREMENT>$50K 69 NO ESCALATION | 82,633 |  | 82633 | NELSON R | 1 | 1 |  |  | P | BILL M |  |  |  | 10-028 | 10-031 | 10-064 | 10-066 | 12-028F |  | 12-018F |  | 11-043 | 0 | 32112A | 10-036 | 0 | 82633 | 8263300 | 100 | 13-009F |  |
| 1321121080 |  | Vend Fab HVPS Peg Point #13 Ship and Accept unit #10 |  | 504d | 2010-01-04 A | 2012-01-16 A | 1321121075 FS-437d | 100% | 2010-01-04 | 2012-01-13 | PROCUREMENT>$50K 69 NO ESCALATION | 82,633 |  | 82633 | NELSON R | 1 | 1 |  |  | P | BILL M |  |  |  | 10-028 | 10-031 | 10-064 | 10-066 | 12-028F |  | 12-018F |  | 11-043 | 0 | 32112A | 10-036 | 0 | 82633 | 8263300 | 100 | 13-009F |  |
| 1321121085 |  | Re-Baseline Actuals Adjustment |  | 1d | 2013-08-30 A | 2013-08-30 A |  | 100% | 2013-09-03 | 2013-09-03 | PROCUREMENT>$50K 69 NO ESCALATION | 56,293.71 |  | 56293.71 |  |  |  |  |  |  |  |  |  |  |  |  |  |  |  |  |  |  |  |  |  |  | 0 | 56293.71 | 5629371 | 100 |  | ADJ |

Notes:
- 1321121015: Explanation: CR 08-049 was supposed to be cost neutral but after implementation was an / ~$500 increase, so that amount was deducted from this activity to bring it back / to no cost increase. / After further investigation of CR 08-049 resource rates in P3e it was / determined that the rates were incorrect ($39.78) for some of the Mechanical / Techs on some of the activities that were copied from the what if schedule for / this change request. After recalculating the resource rates the correct rate / ($39.20) was applied to all the Mechanical Techs which made the overall change / request with a lower budget than the previous project. So this activity / procurement over $50k resource was increased by $4,375.80 to ensure a / nuetral cost impact.

| ID | WBS | Activity | Type | Duration | Start | Finish | Predecessors | Complete | Planned start | Planned finish | Resources | Cost | Actual cost | Calculated Remaining Total Cost | MONTHLY EV COST | RESP - Responsibility | STRT%COMP for CM EVM | FNSH%COMP for CM EVM | EVMS Reporting Codes | CAM RESPONSIBLE | CR 08-049 | CR 10-028 | CR 10-031 | CR 10-064 | CR 10-066 | Remaining Material Cost Based on % Compl | Claimed Material Cost Based on % Complet | Initial Claimed Material Calc | Claimed Material Divider | Activities with Steps | CR 12-018 | CR 12-028 | CR 13-009 | LOE Divider | LOE Multiplier | Milestone Level | CR 11-001 | CR 10-056 | LOE % Pre Calc | LOE % | CR 11-015 | Installation | CR 12-001 | CR 08-052 | CR 10-036 | MARCH!!! | CR 11-043 | ReBaseline Actuals Adjustment |
| --- | --- | --- | --- | --- | --- | --- | --- | --- | --- | --- | --- | --- | --- | --- | --- | --- | --- | --- | --- | --- | --- | --- | --- | --- | --- | --- | --- | --- | --- | --- | --- | --- | --- | --- | --- | --- | --- | --- | --- | --- | --- | --- | --- | --- | --- | --- | --- | --- |
|  | 2 | **1.3.2.1.1.2.2 High Power Amplifier** |  |  | 2009-10-15 | 2013-08-30 |  |  |  |  |  |  |  |  |  |  |  |  |  |  |  |  |  |  |  |  |  |  |  |  |  |  |  |  |  |  |  |  |  |  |  |  |  |  |  |  |  |  |
| 1321122035 |  | Bid HPA Components, Subassemblies |  | 191d | 2009-10-15 A | 2010-07-26 A | 9-100M | 100% |  |  | ELEC TECH [80 h]; MECH TECH [120 h]; ELEC ENG [20 h] | 9,650.2 | 9,650.2 | 0 | 9650.2 | NELSON R | 1 | 1 | H | BILL M | 08-049 | 10-028 | 10-031 | 10-064 | 10-066 |  |  |  |  |  |  |  |  |  |  |  |  |  |  |  |  |  |  |  |  |  |  |  |
| 1321122000 |  | Order/Receive Components: Aux PS, Cabling |  | 392d | 2009-11-30 A | 2011-06-30 A | 9-100M | 100% |  |  | PROCUREMENT<$50K 60; ELEC ENG [40 h]; ELEC DES [80 h]; ELEC TECH [80 h] | 305,927.19 | 9,907.89 | 0 | 305781.29558 | NELSON R | 1 | 1 | S | BILL M | 08-049 | 10-028 | 10-031 | 10-064 | 10-066 | 0 | 296019.29558 | 29601929.558 | 100 | ST | 12-018F | 12-028F | 13-009F |  |  |  |  |  |  |  |  |  |  |  |  |  |  |  |
| 1321122045LOE |  | Engineering Oversight FY10 |  | 128d | 2010-04-01 A | 2010-09-30 A | 1321122000M FS-120d, 9-100M FS+120d | 100% |  |  | ELEC ENG [201 h] | 13,320.27 | 13,320.27 | 0 | 13320.27 | NELSON R | 1 | 1 | E | BILL M |  | 10-028 | 10-031 | 10-064 | 10-066 |  |  |  |  |  | 12-018F | 12-028F | 13-009F | 100 | 100 |  |  |  |  |  |  |  |  |  |  |  |  |  |
| 1321122035M |  | Award HPA Components | milestone | 0d | 2010-07-26 A | 2010-07-26 A | 1321122035 | 100% | 2010-08-31 | 2010-08-31 |  |  |  |  | 0 | NELSON R | 1 | 1 | M | BILL M | 08-049 | 10-028 | 10-031 | 10-064 | 10-066 |  |  |  |  |  |  |  |  |  |  | 6 |  |  |  |  |  |  |  |  |  |  |  |  |
| 1321122041 |  | Procure AC Power Materials (208 VAC) |  | 132d | 2010-07-30 A | 2011-02-14 A | 9-100M FS+205d | 100% |  |  | ELEC ENG [40 h]; SUPPLIES & MATERIALS | 47,707.07 | 2,707.07 | 0 | 47650.8 | NELSON R | 1 | 1 | D | BILL M | 08-049 | 10-028 | 10-031 |  | 10-066 |  |  |  |  |  | 12-018F | 12-028F | 13-009F |  |  |  |  |  |  |  |  |  |  |  |  |  |  |  |
| 1321122042 |  | Install RF Zone 208 VAC FY10 |  | 221.8d | 2010-09-28 A | 2011-08-19 A | 1321122041 FS-40d | 100% |  |  | SKLLD TRADE [72 h] | 2,333.27 | 2,333.27 | 0 | 2262.24 | NELSON R | 1 | 1 | H | BILL M | 08-049 | 10-028 | 10-031 |  | 10-066 |  |  |  |  |  | 12-018F | 12-028F | 13-009F |  |  |  | 11-001 |  |  |  |  |  |  |  |  |  |  |  |
| 1321122042a |  | Install RF Zone 208 VAC FY11 |  | 221.57d | 2010-09-28 A | 2011-08-19 A | 1321122041 FS-40d | 100% |  |  | SKLLD TRADE [888 h] | 28,776.94 | 28,776.94 | 0 | 28788.96 | NELSON R | 1 | 1 | H | BILL M | 08-049 | 10-028 | 10-031 |  | 10-066 |  |  |  |  |  | 12-018F | 12-028F | 13-009F |  |  |  | 11-001 |  |  |  |  |  |  |  |  |  |  |  |
| 1321122020 |  | Bid Solenoid PS (10) |  | 54.48d | 2010-10-01 A | 2010-12-20 A | 9-100M FS+60d | 100% |  |  | ELEC ENG [20 h] | 1,367.6 | 1,367.6 | 0 | 1325.4 | NELSON R | 1 | 1 | H | BILL M | 08-049 | 10-028 | 10-031 | 10-064 | 10-066 |  |  |  |  |  | 12-018F | 12-028F | 13-009F |  |  |  |  | 10-056 |  |  |  |  |  |  |  |  |  |  |
| 1321122046LOE |  | Engineering Oversight FY11 |  | 248d | 2010-10-01 A | 2011-09-30 A | 1321122045LOE | 100% |  |  | ELEC ENG [390 h] | 26,668.2 | 26,668.2 | 0 | 26668.2 | NELSON R | 1 | 1 | E | BILL M |  | 10-028 | 10-031 | 10-064 | 10-066 |  |  |  |  |  | 12-018F | 12-028F | 13-009F | 100 | 100 |  |  |  | 8.46774193 | 91.53225806 |  |  |  |  |  |  |  |  |
| 1321122040 |  | Fabricate HPA Components |  | 264d | 2010-12-15 A | 2012-01-16 A | 9-100M FS+63d, 1321122035M | 100% | 2010-12-15 | 2012-01-13 | MECH TECH [80 h]; PROCUREMENT<$50K 60 | 314,400.16 | 3,473.42 | 0 | 314265.94212 | NELSON R | 1 | 1 | S | BILL M | 08-049 | 10-028 | 10-031 | 10-064 | 10-066 | 0 | 310926.74212 | 31092674.212 | 100 | ST |  |  |  |  |  |  |  |  |  |  |  |  |  |  |  |  |  |  |
| 1321122020M |  | Award Solenoid PS | milestone | 0d | 2011-01-19 A | 2011-01-19 A | 1321122020 | 100% | 2011-02-01 | 2011-02-01 |  |  |  |  | 0 | NELSON R | 1 | 1 | M | BILL M | 08-049 | 10-028 | 10-031 | 10-064 | 10-066 |  |  |  |  |  | 12-018F | 12-028F | 13-009F |  |  | 6 |  | 10-056 |  |  |  |  |  |  |  |  |  |  |
| 1321122025 |  | Fabricate, Receive & Test Solenoid PS (Original Labor) |  | 177d | 2011-02-14 A | 2011-10-24 A | 1321122020M | 100% |  |  | ELEC TECH [80 h]; ELEC ENG [20 h] | 4,802.98 | 4,802.98 | 0 | 4641.4 | NELSON R | 1 | 1 | D | BILL M | 08-049 | 10-028 | 10-031 | 10-064 | 10-066 |  |  |  |  |  | 12-018F | 12-028F | 13-009F |  |  |  |  | 10-056 |  |  |  |  |  |  |  |  |  |  |
| 1321122026 |  | Fabricate Solenoid PS |  | 177d | 2011-02-14 A | 2011-10-24 A | 1321122025 FS-44d, 9-100M FS+230d | 100% |  |  | PROCUREMENT<$50K 60 NO ESCALATION FY11; PROCUREMENT>$50K 69 NO ESCALATION FY11 | 258,750.68 |  | 0 | 258750.68 | NELSON R | 1 | 1 | D | BILL M |  |  |  | 10-064 | 10-066 | 0 | 258750.68 | 25875068 | 100 |  | 12-018F | 12-028F | 13-009F |  |  |  |  | 10-056 |  |  | 11-015 |  |  |  |  |  |  |  |
| 1321122050 |  | Fabricate HPA #1 |  | 98d | 2011-03-01 A | 2011-07-18 A | 1321122040 FS-40d | 100% |  |  | SUPPLIES & MATERIALS; ELEC DES [60 h]; ELEC TECH [80 h]; MECH TECH [480 h] | 35,550.74 | 27,032.2 | 0 | 34716.14088 | NELSON R | 1 | 1 | H | BILL M | 08-049 | 10-028 | 10-031 | 10-064 | 10-066 |  |  |  |  |  |  |  |  |  |  |  |  |  |  |  |  |  |  |  |  |  |  |  |
| 1321122000M |  | Components: Aux PS, Cabling Received | milestone | 0d | 2011-06-30 A | 2011-06-30 A | 1321122000 | 100% | 2011-07-01 | 2011-07-01 |  |  |  |  | 0 | NELSON R | 1 | 1 | M | BILL M | 08-049 | 10-028 | 10-031 | 10-064 | 10-066 |  |  |  |  |  | 12-018F | 12-028F | 13-009F |  |  | 6 |  |  |  |  |  |  |  |  |  |  |  |  |
| 1321122005 |  | Fabricate: Aux PS, Cabling FY10 |  | 12d | 2011-06-30 A | 2011-07-18 A | 1321122000M FS-23d | 100% |  |  | ELEC TECH [3456.4 h] | 147,830.23 | 147,830.23 | 0 | 143265.293 | NELSON R | 1 | 1 | U | BILL M | 08-049 | 10-028 | 10-031 | 10-064 | 10-066 |  |  |  |  |  | 12-018F | 12-028F | 13-009F |  |  |  | 11-001 |  |  |  |  |  |  |  |  |  |  |  |
| 1321122005a |  | Fabricate: Aux PS, Cabling FY11 |  | 11d | 2011-06-30 A | 2011-07-15 A | 1321122000M | 100% |  |  | ELEC TECH [463.66 h] | 19,830.74 | 19,830.74 | 0 | 19830.7382 | NELSON R | 1 | 1 | U | BILL M | 08-049 | 10-028 | 10-031 | 10-064 | 10-066 |  |  |  |  |  | 12-018F | 12-028F | 13-009F |  |  |  | 11-001 |  |  |  |  |  |  |  |  |  |  |  |
| 1321122015 |  | Install: Aux PS, Cabling FY11 |  | 342.43d | 2011-06-30 A | 2012-11-12 A | 1321122010a FS-140d, 3A-03M, 9-110M, 1321122010 FS-140d | 100% |  |  | ELEC TECH [519.34 h]; ELEC ENG [10.39 h] | 23,580.37 | 23,580.37 | 0 | 22922.639528 | NELSON R | 1 | 1 | U | BILL M | 08-049 | 10-028 | 10-031 | 10-064 | 10-066 |  |  |  |  |  | 12-018F | 12-028F | 13-009F |  |  |  |  |  |  |  |  | Install | 12-001 |  |  |  |  |  |
| 1321122015a |  | Install: Aux PS, Cabling FY12 |  | 343d | 2011-06-30 A | 2012-11-12 A | 1321122015 FS-200d | 100% |  |  | ELEC TECH [480.66 h]; ELEC ENG [9.61 h] | 21,824.97 | 21,824.97 | 0 | 21889.6074 | NELSON R | 1 | 1 | U | BILL M | 08-049 | 10-028 | 10-031 | 10-064 | 10-066 |  |  |  |  |  | 12-018F | 12-028F | 13-009F |  |  |  |  |  |  |  |  |  | 12-001 |  |  |  |  |  |
| 1321122055 |  | Fabricate HPA #2 FY10 |  | 8d | 2011-06-30 A | 2011-07-12 A | 1321122050 FS-40d | 100% |  |  | ELEC TECH [28 h]; MECH TECH [168 h]; ELEC DES [7 h] | 8,775.97 | 8,775.97 | 0 | 8505 | NELSON R | 1 | 1 | H | BILL M | 08-049 | 10-028 | 10-031 | 10-064 | 10-066 |  |  |  |  |  |  |  |  |  |  |  | 11-001 |  |  |  |  |  |  |  |  |  |  |  |
| 1321122055a |  | Fabricate HPA #2 FY11 |  | 8d | 2011-06-30 A | 2011-07-12 A | 1321122055 FS-50d, 1321122050 FS-40d | 100% |  |  | ELEC DES [13 h]; ELEC TECH [52 h]; MECH TECH [312 h] | 16,298.23 | 16,298.23 | 0 | 16298.23 | NELSON R | 1 | 1 | H | BILL M | 08-049 | 10-028 | 10-031 | 10-064 | 10-066 |  |  |  |  |  |  |  |  |  |  |  | 11-001 |  |  |  |  |  |  |  |  |  |  |  |
| 1321122100 |  | Install/Test HPA #1 |  | 6d | 2011-06-30 A | 2011-07-09 A | 132127025a FS-280d, 1321121015, 132127025b FS-280d, 1321121035, 1321122050 | 100% | 2011-06-30 | 2011-07-08 | ELEC TECH [292 h]; MECH TECH [100 h]; SUPPLIES & MATERIALS | 25,586.12 | 16,795.84 | 0 | 25586.12 | NELSON R | 1 | 1 | H | BILL M | 08-049 | 10-028 | 10-031 | 10-064 | 10-066 |  |  |  |  |  |  |  |  |  |  |  |  |  |  |  |  | Install |  | 08-052 | 10-036 |  |  |  |
| 1321122105 |  | Install/Test HPA #2 |  | 65d | 2011-06-30 A | 2011-09-30 A | 132111050F FS-100d, 1321121040, 1321122055, 1321122055a | 100% |  |  | MECH TECH [100 h]; ELEC TECH [292 h] | 16,795.84 | 16,795.84 | 0 | 16795.84 | NELSON R | 1 | 1 | H | BILL M | 08-049 | 10-028 | 10-031 | 10-064 | 10-066 |  |  |  |  |  |  |  |  |  |  |  |  |  |  |  |  | Install |  | 08-052 | 10-036 |  |  |  |
| 1321122010 |  | Test: Aux PS, Cabling FY10 |  | 37d | 2011-07-11 A | 2011-08-30 A | 1321122005a FS-30d, 1321122005 FS-30d | 100% |  |  | ELEC TECH [424.27 h]; ELEC ENG [13.26 h] | 19,052.75 | 19,052.75 | 0 | 18464.7317 | NELSON R | 1 | 1 | U | BILL M | 08-049 | 10-028 | 10-031 | 10-064 | 10-066 |  |  |  |  |  | 12-018F | 12-028F | 13-009F |  |  |  | 11-001 |  |  |  |  |  |  |  |  |  |  |  |
| 1321122010a |  | Test: Aux PS, Cabling FY11 |  | 36d | 2011-07-11 A | 2011-08-29 A | 1321122010 FS-40d, 1321122005a FS-160d, 1321122005 FS-160d | 100% |  |  | ELEC TECH [215.6 h]; ELEC ENG [6.8 h] | 9,686.19 | 9,686.19 | 0 | 9687.6533 | NELSON R | 1 | 1 | U | BILL M | 08-049 | 10-028 | 10-031 | 10-064 | 10-066 |  |  |  |  |  | 12-018F | 12-028F | 13-009F |  |  |  | 11-001 |  |  |  |  |  |  |  |  |  |  |  |
| 1321122060 |  | Fabricate HPA #3 FY10 |  | 30d | 2011-07-11 A | 2011-08-19 A | 1321122055 FS-45d, 1321122055a FS-45d | 100% |  |  | ELEC TECH [1.33 h]; MECH TECH [8 h]; ELEC DES [0.33 h] | 417.59 | 417.59 | 0 | 404.7037 | NELSON R | 1 | 1 | H | BILL M | 08-049 | 10-028 | 10-031 | 10-064 | 10-066 |  |  |  |  |  | 12-018F | 12-028F | 13-009F |  |  |  | 11-001 |  |  |  |  |  |  |  |  |  |  |  |
| 1321122060a |  | Fabricate HPA #3 FY11 |  | 30d | 2011-07-11 A | 2011-08-19 A | 1321122055a FS-45d, 1321122055 FS-45d, 1321122060 FS-59d | 100% |  |  | ELEC TECH [78.67 h]; MECH TECH [472 h]; ELEC DES [19.67 h] | 24,656.61 | 24,656.61 | 0 | 24656.6024 | NELSON R | 1 | 1 | H | BILL M | 08-049 | 10-028 | 10-031 | 10-064 | 10-066 |  |  |  |  |  | 12-018F | 12-028F | 13-009F |  |  |  | 11-001 |  |  |  |  |  |  |  |  |  |  |  |
| 1321122110 |  | Install/Test HPA #3 |  | 170d | 2011-07-11 A | 2012-03-19 A | 1321122060 FS-15d, 1321122060a FS-15d, 1321121045 | 100% |  |  | ELEC TECH [292 h]; MECH TECH [100 h] | 17,144.59 | 17,144.59 | 0 | 16795.84 | NELSON R | 1 | 1 | H | BILL M | 08-049 | 10-028 | 10-031 | 10-064 | 10-066 |  |  |  |  |  |  | 12-028F |  |  |  |  |  |  |  |  |  | Install |  | 08-052 | 10-036 |  |  |  |
| 1321122030 |  | Install Solenoid PS FY11 |  | 359d | 2011-07-18 A | 2013-01-24 A | 9-110M FS+60d, 1321122025 FS-40d, 1321122026 FS-80d | 100% | 2011-07-18 | 2012-12-21 | ELEC TECH [72.45 h] | 3,198.9 | 3,203.38 | 0 | 3098.6865 | NELSON R | 1 | 1 | U | BILL M | 08-049 | 10-028 | 10-031 | 10-064 | 10-066 |  |  |  |  |  | 12-018F | 12-028F | 13-009F |  |  |  |  |  |  |  | 11-015 | Install | 12-001 |  |  | XX |  |  |
| 1321122030a |  | Install Solenoid PS FY12 |  | 359d | 2011-07-18 A | 2013-01-24 A | 1321122030 FS-200d | 100% | 2011-07-18 | 2012-12-21 | ELEC TECH [87.55 h] | 3,865.62 | 3,871.1 | 0 | 3863.5815 | NELSON R | 1 | 1 | U | BILL M | 08-049 | 10-028 | 10-031 | 10-064 | 10-066 |  |  |  |  |  | 12-018F | 12-028F | 13-009F |  |  |  |  |  |  |  | 11-015 |  | 12-001 |  |  | XX |  |  |
| 1321122120 |  | Install/Test HPA #5 FY11 Frozen by CR 12-028 |  | 154.19d | 2011-07-24 A | 2012-03-12 A | 1321121055, 1321122070 FS-225d | 100% | 2011-07-25 | 2012-03-12 | MECH TECH [68.25 h]; ELEC TECH [199.3 h] | 11,712.29 | 11,712.29 | 0 | 11463.5885 | NELSON R | 1 | 1 | H | BILL M | 08-049 | 10-028 | 10-031 | 10-064 | 10-066 |  |  |  |  |  | 12-018F |  | 13-009F |  |  |  |  |  |  |  |  | Install | 12-001 | 08-052 | 10-036 |  |  |  |
| 1321122120a |  | Install/Test HPA #5 FY12 Frozen by CR 12-028 |  | 155d | 2011-07-24 A | 2012-03-12 A | 1321122120 FS-225d | 100% | 2011-07-25 | 2012-03-12 | MECH TECH [31.75 h]; ELEC TECH [92.7 h] | 5,448.22 | 5,448.22 | 0 | 5501.821 | NELSON R | 1 | 1 | H | BILL M | 08-049 | 10-028 | 10-031 | 10-064 | 10-066 |  |  |  |  |  | 12-018F |  | 13-009F |  |  |  |  |  |  |  |  |  | 12-001 | 08-052 | 10-036 |  |  |  |
| 1321122115 |  | Install/Test HPA #4 FY11 |  | 158.98d | 2011-07-26 A | 2012-03-19 A | 1321121050 FS-20d, 1321122065 FS-20d | 100% |  |  | ELEC TECH [246.02 h]; MECH TECH [84.25 h] | 14,465.06 | 14,465.06 | 0 | 14150.9229 | NELSON R | 1 | 1 | H | BILL M | 08-049 | 10-028 | 10-031 | 10-064 | 10-066 |  |  |  |  |  | 12-018F |  |  |  |  |  |  |  |  |  |  | Install | 12-001 | 08-052 | 10-036 |  |  |  |
| 1321122115a |  | Install/Test HPA #4 FY12 |  | 159d | 2011-07-26 A | 2012-03-19 A | 1321122115 FS-80d | 100% |  |  | MECH TECH [15.75 h]; ELEC TECH [45.98 h] | 2,703.64 | 2,703.64 | 0 | 2729.0274 | NELSON R | 1 | 1 | H | BILL M | 08-049 | 10-028 | 10-031 | 10-064 | 10-066 |  |  |  |  |  | 12-018F |  |  |  |  |  |  |  |  |  |  |  | 12-001 | 08-052 | 10-036 |  |  |  |
| 1321122065 |  | Fabricate HPA #4 |  | 135d | 2011-08-01 A | 2012-02-20 A | 1321122060a FS-10d, 1321122060 FS-10d | 100% | 2011-08-01 | 2012-02-17 | ELEC DES [20 h]; ELEC TECH [80 h]; MECH TECH [480 h] | 25,611.84 | 25,611.84 | 0 | 25074.2 | NELSON R | 1 | 1 | H | BILL M | 08-049 | 10-028 | 10-031 | 10-064 | 10-066 |  |  |  |  |  | 12-018F | 12-028F | 13-009F |  |  |  |  |  |  |  |  |  |  |  |  |  |  |  |
| 1321122070 |  | Fabricate HPA #5 Frozen by CR 12-028 |  | 150d | 2011-08-01 A | 2012-03-12 A | 1321122065 FS-42.5d | 100% |  |  | MECH TECH [480 h]; ELEC DES [20 h]; ELEC TECH [80 h] | 25,637.84 | 25,637.84 | 0 | 25074.2 | NELSON R | 1 | 1 | H | BILL M | 08-049 | 10-028 | 10-031 | 10-064 | 10-066 |  |  |  |  |  | 12-018F | 12-028F | 13-009F |  |  |  |  |  |  |  |  |  |  |  |  |  |  |  |
| 1321122075 |  | Fabricate HPA #6 Frozen by CR 12-028 |  | 150d | 2011-08-01 A | 2012-03-12 A | 1321122070 FS-200d | 100% |  |  | ELEC TECH [80 h]; MECH TECH [480 h]; ELEC DES [20 h] | 25,637.84 | 25,637.84 | 0 | 25074.2 | NELSON R | 1 | 1 | H | BILL M | 08-049 | 10-028 | 10-031 | 10-064 | 10-066 |  |  |  |  |  | 12-018F | 12-028F | 13-009F |  |  |  |  |  |  |  |  |  |  |  |  |  |  |  |
| 1321122080 |  | Fabricate HPA #7 Frozen by CR 12-028 |  | 116d | 2011-09-19 A | 2012-03-12 A | 1321122075 FS-225d | 100% |  |  | ELEC DES [20 h]; ELEC TECH [80 h]; MECH TECH [480 h] | 25,803.04 | 25,803.04 | 0 | 25074.2 | NELSON R | 1 | 1 | H | BILL M | 08-049 | 10-028 | 10-031 | 10-064 | 10-066 |  |  |  |  |  | 12-018F | 12-028F | 13-009F |  |  |  |  |  |  |  |  |  |  |  |  |  |  |  |
| 1321122085 |  | Fabricate HPA #8 Frozen by CR 12-028 |  | 116d | 2011-09-19 A | 2012-03-12 A | 1321122080 FS-50d | 100% |  |  | ELEC TECH [80 h]; MECH TECH [480 h]; ELEC DES [20 h] | 25,803.04 | 25,803.04 | 0 | 25074.2 | NELSON R | 1 | 1 | H | BILL M | 08-049 | 10-028 | 10-031 | 10-064 | 10-066 |  |  |  |  |  | 12-018F | 12-028F | 13-009F |  |  |  |  |  |  |  |  |  |  |  |  |  |  |  |
| 1321122090 |  | Fabricate HPA #9 Frozen by CR 12-028 |  | 116d | 2011-09-19 A | 2012-03-12 A | 1321122085 FS-60d | 100% |  |  | ELEC DES [20 h]; ELEC TECH [80 h]; MECH TECH [480 h] | 25,803.04 | 25,803.04 | 0 | 25074.2 | NELSON R | 1 | 1 | H | BILL M | 08-049 | 10-028 | 10-031 | 10-064 | 10-066 |  |  |  |  |  | 12-018F | 12-028F | 13-009F |  |  |  |  |  |  |  |  |  |  |  |  |  |  |  |
| 1321122095 |  | Fabricate HPA #10 Frozen by CR 12-028 |  | 116d | 2011-09-19 A | 2012-03-12 A | 1321122090 FS-65d | 100% |  |  | MECH TECH [480 h]; ELEC DES [20 h]; ELEC TECH [80 h] | 25,803.04 | 25,803.04 | 0 | 25074.2 | NELSON R | 1 | 1 | H | BILL M | 08-049 | 10-028 | 10-031 | 10-064 | 10-066 |  |  |  |  |  | 12-018F | 12-028F | 13-009F |  |  |  |  |  |  |  |  |  |  |  |  |  |  |  |
| 1321122047LOE |  | Engineering Oversight FY12 |  | 31d | 2011-10-03 A | 2011-11-14 A | 1321122046LOE | 100% |  |  | ELEC ENG [49 h] | 3,457.44 | 3,457.44 | 0 | 3457.44 | NELSON R | 1 | 1 | E | BILL M |  | 10-028 | 10-031 | 10-064 | 10-066 |  |  |  |  |  | 12-018F | 12-028F | 13-009F | 100 | 100 |  |  |  | 32.25806451 | 67.74193548 |  |  |  |  |  |  |  |  |
| 1321122125 |  | Install/Test HPA #6 Frozen by CR 12-028 |  | 8d | 2012-03-01 A | 2012-03-12 A | 1321122075, 1321121060 | 100% |  |  | MECH TECH [53.26 h]; ELEC TECH [155.52 h] | 9,229.97 | 9,229.97 | 0 | 9229.972 | NELSON R | 1 | 1 | H | BILL M | 08-049 | 10-028 | 10-031 | 10-064 | 10-066 |  |  |  |  |  | 12-018F | 12-028 | 13-009F |  |  |  |  |  |  |  |  | Install |  | 08-052 | 10-036 |  | 11-043 |  |
| 1321122130 |  | Install/Test HPA #7 Frozen by CR 12-028 |  | 8d | 2012-03-01 A | 2012-03-12 A | 1321121065, 1321122080 | 100% |  |  | ELEC TECH [122.2 h]; MECH TECH [41.85 h] | 7,252.5 | 7,252.5 | 0 | 7252.5 | NELSON R | 1 | 1 | H | BILL M | 08-049 | 10-028 | 10-031 | 10-064 | 10-066 |  |  |  |  |  | 12-018F | 12-028 | 13-009F |  |  |  |  |  |  |  |  | Install |  | 08-052 | 10-036 |  | 11-043 |  |
| 1321122135 |  | Install/Test HPA #8 Frozen by CR 12-028 |  | 8d | 2012-03-01 A | 2012-03-12 A | 1321122085, 1321121070 | 100% |  |  | MECH TECH [31.49 h]; ELEC TECH [91.96 h] | 5,457.61 | 5,457.61 | 0 | 5457.6104 | NELSON R | 1 | 1 | H | BILL M | 08-049 | 10-028 | 10-031 | 10-064 | 10-066 |  |  |  |  |  | 12-018F | 12-028 | 13-009F |  |  |  |  |  |  |  |  | Install |  | 08-052 | 10-036 |  | 11-043 |  |
| 1321122140 |  | Install/Test HPA #9 Frozen by CR 12-028 |  | 8d | 2012-03-01 A | 2012-03-12 A | 1321121075, 1321122090 | 100% |  |  | ELEC TECH [32.44 h]; MECH TECH [11.11 h] | 1,925.31 | 1,925.31 | 0 | 1925.3056 | NELSON R | 1 | 1 | H | BILL M | 08-049 | 10-028 | 10-031 | 10-064 | 10-066 |  |  |  |  |  | 12-018F | 12-028 | 13-009F |  |  |  |  |  |  |  |  | Install |  | 08-052 | 10-036 |  | 11-043 |  |
| 1321122145 |  | Install/Test HPA #10 Frozen by CR 12-028 |  | 8d | 2012-03-01 A | 2012-03-12 A | 1321121080, 1321122095 | 100% |  |  | ELEC TECH [32.63 h]; MECH TECH [11.17 h] | 1,936.35 | 1,936.35 | 0 | 1936.3567 | NELSON R | 1 | 1 | H | BILL M | 08-049 | 10-028 | 10-031 | 10-064 | 10-066 |  |  |  |  |  | 12-018F | 12-028 | 13-009F |  |  |  |  |  |  |  |  | Install |  | 08-052 | 10-036 |  | 11-043 |  |
| 1321122210 |  | Reverse Entry Per CR 12-028 |  | 8d | 2012-03-01 A | 2012-03-12 A | 9-120M FS+100d | 100% |  |  | ELEC TECH [-800 h]; MECH TECH [-1600 h]; ELEC DES [-61.36 h] | -109,507.29 | -109,507.29 |  |  | NELSON R | 1 | 1 | Z | BILL M | 08-049 | 10-028 | 10-031 | 10-064 | 10-066 |  |  |  |  |  | 12-018F | 12-028 |  |  |  |  |  |  |  |  |  |  |  | 08-052 | 10-036 |  | 11-043 |  |
| 1321122150 |  | Fabricate HPA #5 Revised per CR 12-028 |  | 158d | 2012-03-12 A | 2012-10-22 A | 132127030 FS-300d, 1321122065, 132127035 FS-300d | 100% |  |  | ELEC TECH [40 h]; MECH TECH [240 h]; ELEC DES [10 h] | 12,977.75 | 12,977.75 | 0 | 13349.2 | NELSON R | 1 | 1 | H | BILL M | 08-049 | 10-028 | 10-031 | 10-064 | 10-066 |  |  |  |  |  | 12-018F | 12-028 |  |  |  |  |  |  |  |  |  |  |  |  |  |  |  |  |
| 1321122155 |  | Fabricate HPA #6 Revised per CR 12-028 |  | 195d | 2012-03-12 A | 2012-12-17 A | 1321122150 FS-150d | 100% | 2012-03-12 | 2012-12-14 | ELEC TECH [40 h]; MECH TECH [240 h]; ELEC DES [10 h] | 13,048.24 | 13,049.77 | 0 | 13349.2 | NELSON R | 1 | 1 | H | BILL M | 08-049 | 10-028 | 10-031 | 10-064 | 10-066 |  |  |  |  |  | 12-018F | 12-028 | 13-009F |  |  |  |  |  |  |  |  |  |  |  |  |  |  |  |
| 1321122160 |  | Fabricate HPA #7 Revised per CR 12-028 |  | 45d | 2012-10-15 A | 2012-12-17 A | 1321122155 FS-30d | 100% | 2012-10-15 | 2012-12-18 | ELEC DES [10 h]; ELEC TECH [40 h]; MECH TECH [240 h] | 13,349.2 | 13,349.2 | 0 | 13349.2 | NELSON R | 1 | 1 | H | BILL M | 08-049 | 10-028 | 10-031 | 10-064 | 10-066 |  |  |  |  |  | 12-018F | 12-028 | 13-009F |  |  |  |  |  |  |  |  |  |  |  |  |  |  |  |
| 1321122165 |  | Fabricate HPA #8 Revised per CR 12-028 |  | 40d | 2012-11-12 A | 2013-02-28 A | 1321122160 FS-20d | 100% | 2012-11-12 | 2013-01-16 | MECH TECH [240 h]; ELEC DES [10 h]; ELEC TECH [40 h] | 13,349.2 | 13,349.2 | 0 | 13349.2 | NELSON R | 1 | 1 | H | BILL M | 08-049 | 10-028 | 10-031 | 10-064 | 10-066 |  |  |  |  |  | 12-018F | 12-028 | 13-009F |  |  |  |  |  |  |  |  |  |  |  |  | XX |  |  |
| 1321122180 |  | Install/Test HPA #5 Revised per CR 12-028 |  | 18d | 2012-11-13 A | 2013-01-31 A | 1321121055, 1321122150 | 100% | 2012-11-13 | 2012-12-10 | MECH TECH [100 h]; ELEC TECH [292 h] | 17,883.68 | 17,883.68 | 0 | 17883.68 | NELSON R | 1 | 1 | H | BILL M | 08-049 | 10-028 | 10-031 | 10-064 | 10-066 |  |  |  |  |  | 12-018F | 12-028 | 13-009F |  |  |  |  |  |  |  |  |  | 12-001 | 08-052 | 10-036 | XX |  |  |
| 1321122170 |  | Fabricate HPA #9 Revised per CR 12-028 |  | 45d | 2012-11-19 A | 2013-03-11 A | 1321122165 FS-30d | 100% | 2012-11-19 | 2013-01-31 | MECH TECH [240 h]; ELEC DES [10 h]; ELEC TECH [40 h] | 13,349.2 | 13,349.2 | 0 | 13349.2 | NELSON R | 1 | 1 | H | BILL M | 08-049 | 10-028 | 10-031 | 10-064 | 10-066 |  |  |  |  |  | 12-018F | 12-028 | 13-009F |  |  |  |  |  |  |  |  |  |  |  |  | XX |  |  |
| 1321122185 |  | Install/Test HPA #6 Revised per CR 12-028 |  | 31d | 2012-11-19 A | 2013-04-15 A | 1321122155 FS-20d, 1321122180 FS-26d, 1321121060 | 100% | 2012-11-19 | 2013-01-10 | MECH TECH [100 h]; ELEC TECH [292 h] | 17,883.68 | 17,883.68 | 0 | 17883.68 | NELSON R | 1 | 1 | S | BILL M | 08-049 | 10-028 | 10-031 | 10-064 | 10-066 |  |  |  |  | ST | 12-018F | 12-028 | 13-009F |  |  |  |  |  |  |  |  |  |  | 08-052 | 10-036 | XX | 11-043 |  |
| 1321122190 |  | Install/Test HPA #7 Revised per CR 12-028 |  | 44d | 2012-11-21 A | 2013-05-24 A | 1321122185 FS-40d, 1321121065, 1321122160 FS-30d | 100% | 2012-11-21 | 2013-02-01 | MECH TECH [100 h]; ELEC TECH [292 h] | 17,883.68 | 17,883.68 | 0 | 17883.68 | NELSON R | 1 | 1 | S | BILL M | 08-049 | 10-028 | 10-031 | 10-064 | 10-066 |  |  |  |  | ST | 12-018F | 12-028 | 13-009F |  |  |  |  |  |  |  |  |  |  | 08-052 | 10-036 | XX | 11-043 |  |
| 1321122195 |  | Install/Test HPA #8 Revised per CR 12-028 |  | 58d | 2012-11-23 A | 2013-06-14 A | 1321122165 FS-30d, 1321121070, 1321122190 FS-40d | 100% | 2012-11-26 | 2013-02-25 | ELEC TECH [292 h]; MECH TECH [100 h] | 17,883.68 | 17,883.68 | 0 | 17883.68 | NELSON R | 1 | 1 | S | BILL M | 08-049 | 10-028 | 10-031 | 10-064 | 10-066 |  |  |  |  | ST | 12-018F | 12-028 | 13-009F |  |  |  |  |  |  |  |  |  |  | 08-052 | 10-036 | XX | 11-043 |  |
| 1321122175 |  | Fabricate HPA #10 Revised per CR 12-028 |  | 52d | 2012-11-26 A | 2013-03-18 A | 1321122170 FS-45d | 100% | 2012-11-26 | 2013-02-14 | ELEC DES [10 h]; ELEC TECH [40 h]; MECH TECH [240 h] | 13,349.2 | 13,349.2 | 0 | 13349.2 | NELSON R | 1 | 1 | H | BILL M | 08-049 | 10-028 | 10-031 | 10-064 | 10-066 |  |  |  |  |  | 12-018F | 12-028 | 13-009F |  |  |  |  |  |  |  |  |  |  |  |  | XX |  |  |
| 1321122200 |  | Install/Test HPA #9 Revised per CR 12-028 |  | 71d | 2012-11-26 A | 2013-07-15 A | 1321122195 FS-60d, 1321121075, 1321122170 FS-40d | 100% | 2012-11-26 | 2013-03-14 | MECH TECH [100 h]; ELEC TECH [292 h] | 17,883.68 | 17,883.68 | 0 | 17883.68 | NELSON R | 1 | 1 | S | BILL M | 08-049 | 10-028 | 10-031 | 10-064 | 10-066 |  |  |  |  | ST | 12-018F | 12-028 | 13-009F |  |  |  |  |  |  |  |  |  |  | 08-052 | 10-036 |  | 11-043 |  |
| 1321122205 |  | Install/Test HPA #10 Revised per CR 12-028 |  | 83d | 2012-11-27 A | 2013-08-12 A | 1321121080, 1321122175 FS-60d, 1321122200 FS-85d | 100% | 2012-11-27 | 2013-04-02 | ELEC TECH [146 h]; MECH TECH [50 h] | 8,941.84 | 8,941.84 | 1341.276 | 8941.84 | NELSON R | 1 | 1 | S | BILL M | 08-049 | 10-028 | 10-031 | 10-064 | 10-066 |  |  |  |  | ST | 12-018F | 12-028 | 13-009F |  |  |  |  |  |  |  |  |  |  | 08-052 | 10-036 |  | 11-043 |  |
| 1321122215 |  | Re-Baseline Actuals Adjustment |  | 1d | 2013-08-30 A | 2013-08-30 A |  | 100% | 2013-09-03 | 2013-09-03 | PROCUREMENT>$50K 69 NO ESCALATION | -18,680.8 |  |  |  |  |  |  |  |  |  |  |  |  |  |  |  |  | 100 |  |  |  |  |  |  |  |  |  |  |  |  |  |  |  |  |  |  | ADJ |

Notes:
- 1321122000: Steps: Receive filament & mod anode PS (done); Receive interconnect cables (data) (done); Receive aux power supplies for interfaces (done); Receive parts for interface boards (done); Receive parts for reflected power ASSY (done); Receive parts for klystron connection boards (done); Receive parts for RF cabling (done); Receive parts for mod anode laod banks (done); Receive parts for A/C power chasis and cabling (done); Recieve parts for ion pump chasis (done); Receive parts for ARC detectors (done); Receive card cage ASSY (done)
- 1321122040: Steps: Vendor delivers HPA mechanical subassemblies Lot 1 (done); Vendor delivers HPA mechanical subassemblies Lot 2 (done); Vendor delivers HPA mechanical subassemblies Lot 3 (done); Vendor delivers HPA mechanical subassemblies Lot 4 (done); recieve water manifolds (10systems) (done); receive hoses (lot) (done); receive air manifolds (10) (done)
- 1321122185: Steps: install HPA modules (done); interconnect HPA to external systems (done); test/calibrate filament/mod-anode/interlocks/hi-pot (done); install klystrons (done); install hose, leak test (done); HP test (shorts) (done)
- 1321122190: Steps: install HPA modules (done); interconnect HPA to external systems (done); test/calibrate filament/mod-anode/interlocks/hi-pot (done); install klystrons (done); install hose, leak test (done); HP test (shorts) (done)
- 1321122195: Steps: install HPA modules (done); interconnect HPA to external systems (done); test/calibrate filament/mod-anode/interlocks/hi-pot (done); install klystrons (done); install hose, leak test (done); HP test (shorts) (done)
- 1321122200: Steps: install HPA modules (done); interconnect HPA to external systems (done); test/calibrate filament/mod-anode/interlocks/hi-pot (done); install klystrons (done); install hose, leak test (done); HP test (shorts) (done)
- 1321122205: Steps: install HPA modules (done); interconnect HPA to external systems (done); test/calibrate filament/mod-anode/interlocks/hi-pot (done); install klystrons (done); install hose, leak test (done); HP test (shorts) (done)

| ID | WBS | Activity | Type | Duration | Start | Finish | Predecessors | Complete | Planned start | Planned finish | Calendar | Resources | Cost | Actual cost | Calculated Remaining Total Cost | MONTHLY EV COST | RESP - Responsibility | STRT%COMP for CM EVM | FNSH%COMP for CM EVM | EVMS Reporting Codes | CAM RESPONSIBLE | CR 12-028 | CR 10-035 | Remaining Material Cost Based on % Compl | Claimed Material Cost Based on % Complet | Initial Claimed Material Calc | Claimed Material Divider | Advance Purchase Plan > 500K | CR 08-016 | 12 GEV MAJOR PROCUREMENT CATAGORY | Activities with Steps | Installation | CR 09-012 | CR 11-001 | CR 10-028 | CR 10-031 | CR 10-064 | CR 10-066 | CR 12-018 | CR 12-001 | MARCH!!! | Phil Dev | CR 12-053 | In Progress Procurements | Milestone Level | CR 13-003 | ReBaseline Actuals Adjustment | Original Activity ID Rebaseline | PRIOR MONTH EV COST | BOE Labor | BOE Expenses | CR 13-015 | Post Rebaseline |
| --- | --- | --- | --- | --- | --- | --- | --- | --- | --- | --- | --- | --- | --- | --- | --- | --- | --- | --- | --- | --- | --- | --- | --- | --- | --- | --- | --- | --- | --- | --- | --- | --- | --- | --- | --- | --- | --- | --- | --- | --- | --- | --- | --- | --- | --- | --- | --- | --- | --- | --- | --- | --- | --- |
|  | 3 | **1.3.2.1.1.3 WAVEGUIDE COMPONENTS** |  |  | 2009-06-01 | 2013-09-06 |  |  |  |  |  |  |  |  |  |  |  |  |  |  |  |  |  |  |  |  |  |  |  |  |  |  |  |  |  |  |  |  |  |  |  |  |  |  |  |  |  |  |  |  |  |  |  |
| 132113010 |  | Release Prcrmnt: HOM Filter (WVGUIDE COMPON) |  | 21d | 2009-06-01 A | 2009-06-29 A | 132113000 | 100% |  |  |  | ELEC ENG [8 h] | 513.84 | 513.84 | 0 | 530.16 | NELSON R | 1 | 1 | H | BILL M | 12-028F |  |  |  |  |  |  |  |  |  |  |  |  |  |  |  |  |  |  |  |  |  |  |  |  |  |  |  |  |  |  |  |
| 132113030 |  | Receive Responses, Evaluate, Award: HOM Filters (WVGUIDE COMPON) |  | 22d | 2009-06-01 A | 2009-06-30 A | 132113010 | 100% |  |  |  | ELEC ENG [8 h] | 513.84 | 513.84 | 0 | 530.16 | NELSON R | 1 | 1 | H | BILL M | 12-028F |  |  |  |  |  |  |  |  |  |  |  |  |  |  |  |  |  |  |  |  |  |  |  |  |  |  |  |  |  |  |  |
| 132113050 |  | Receive First HOMs (manufacturing delay) (WVGUIDE COMPON) |  | 11d | 2009-06-01 A | 2009-06-15 A | 132113030 | 100% |  |  |  |  |  |  |  | 0 | NELSON R | 1 | 1 | Z | BILL M | 12-028F |  |  |  |  |  |  |  |  |  |  |  |  |  |  |  |  |  |  |  |  |  |  |  |  |  |  |  |  |  |  |  |
| 132113000 |  | Final Tweaking of Waveguide Layout (Klystron specific) (WVGUIDE COMPON) |  | 21d | 2009-07-27 A | 2009-08-24 A | 1212113090M, 1212113170, 132111035 FS+2d | 100% |  |  |  | ELEC ENG [80 h]; SUPPLIES & MATERIALS; MECH DES [80 h] | 12,491.35 | 8,645.6 | 0 | 12560.146834 | NELSON R | 1 | 1 | H | BILL M | 12-028F |  |  |  |  |  |  |  |  |  |  |  |  |  |  |  |  |  |  |  |  |  |  |  |  |  |  |  |  |  |  |  |
| 132113005 |  | Release Prcrmnt: Circulators (WVGUIDE COMPON) |  | 12d | 2009-07-27 A | 2009-08-11 A | 132113000 | 100% |  |  |  | ELEC ENG [8 h] | 513.84 | 513.84 | 0 | 530.16 | NELSON R | 1 | 1 | H | BILL M | 12-028F |  |  |  |  |  |  |  |  |  |  |  |  |  |  |  |  |  |  |  |  |  |  |  |  |  |  |  |  |  |  |  |
| 132113025 |  | Receive Responses, Evaluate, Award: Circulators (WVGUIDE COMPON) |  | 73d | 2009-09-14 A | 2010-01-04 A | 132113005 | 100% |  |  |  | ELEC ENG [8 h] | 527.25 | 527.25 | 0 | 530.16 | NELSON R | 1 | 1 | H | BILL M | 12-028F |  |  |  |  |  |  |  |  |  |  |  |  |  |  |  |  |  |  |  |  |  |  |  |  |  |  |  |  |  |  |  |
| 132113020 |  | Release Prcrmnt: Special Waveguide (WVGUIDE COMPON) |  | 74d | 2009-10-15 A | 2010-02-08 A | 132113000 | 100% |  |  |  | ELEC ENG [8 h] | 530.16 | 530.16 | 0 | 530.16 | NELSON R | 1 | 1 | H | BILL M | 12-028F |  |  |  |  |  |  |  |  |  |  |  |  |  |  |  |  |  |  |  |  |  |  |  |  |  |  |  |  |  |  |  |
| 132113045 |  | Vend Fab Circulators Peg Point #1 Design Review |  | 79d | 2010-01-04 A | 2010-04-26 A | 132113025, 9-100M FS+59d | 100% |  |  |  |  |  |  |  | 0 | NELSON R | 1 | 1 | Z | BILL M | 12-028F | 10-035 |  |  |  |  |  |  |  |  |  |  |  |  |  |  |  |  |  |  |  |  |  |  |  |  |  |  |  |  |  |  |
| 132113045A |  | Vend Fab Circulators Peg Point #2 1st Article Testing |  | 206d | 2010-01-04 A | 2010-10-25 A | 132113045 FS-33d | 100% |  |  |  |  |  |  |  | 0 | NELSON R | 1 | 1 | Z | BILL M | 12-028F | 10-035 |  |  |  |  |  |  |  |  |  |  |  |  |  |  |  |  |  |  |  |  |  |  |  |  |  |  |  |  |  |  |
| 132113045B |  | Vend Fab Circulators Peg Point #3 1st Article Delivery and Acceptance |  | 186d | 2010-01-04 A | 2010-09-27 A | 132113045A FS-75d | 100% |  |  |  | PROCUREMENT<$50K 60 NO ESCALATION | 8,150 |  | 0 | 8150 | NELSON R | 1 | 1 | D | BILL M | 12-028F | 10-035 | 0 | 8150 | 815000 | 100 |  |  |  |  |  |  |  |  |  |  |  |  |  |  |  |  |  |  |  |  |  |  |  |  |  |  |
| 132113045C |  | Vend Fab Circulators Peg Point #4 Units 2-20 Delivery and Acceptance |  | 206d | 2010-01-04 A | 2010-10-25 A | 132113045B FS-103d | 100% |  |  |  | PROCUREMENT<$50K 60 NO ESCALATION; PROCUREMENT>$50K 69 NO ESCALATION | 154,850 |  | 0 | 154850 | NELSON R | 1 | 1 | D | BILL M | 12-028F | 10-035 | 0 | 154850 | 15485000 | 100 |  |  |  |  |  |  |  |  |  |  |  |  |  |  |  |  |  |  |  |  |  |  |  |  |  |  |
| 132113045D |  | Vend Fab Circulators Peg Point #5 Units 21-40 Delivery and Acceptance |  | 221d | 2010-01-04 A | 2010-11-15 A | 132113045C FS-125d | 100% |  |  |  | PROCUREMENT>$50K 69 NO ESCALATION | 163,000 |  | 0 | 163000 | NELSON R | 1 | 1 | D | BILL M | 12-028F | 10-035 | 0 | 163000 | 16300000 | 100 |  |  |  |  |  |  |  |  |  |  |  |  |  |  |  |  |  |  |  |  |  |  |  |  |  |  |
| 132113045F |  | Vend Fab Circulators Peg Point #6 Units 41-60 Delivery and Acceptance |  | 245d | 2010-01-04 A | 2010-12-21 A | 132113045D FS-146d | 100% |  |  |  | PROCUREMENT>$50K 69 NO ESCALATION | 163,000 |  | 0 | 163000 | NELSON R | 1 | 1 | D | BILL M | 12-028F | 10-035 | 0 | 163000 | 16300000 | 100 |  |  |  |  |  |  |  |  |  |  |  |  |  |  |  |  |  |  |  |  |  |  |  |  |  |  |
| 132113045G |  | Vend Fab Circulators Peg Point #7 Units 61-84 Delivery and Acceptance |  | 265d | 2010-01-04 A | 2011-01-27 A | 132113045F FS-168d | 100% |  |  |  | PROCUREMENT>$50K 69 NO ESCALATION | 195,600 |  | 0 | 195600 | NELSON R | 1 | 1 | D | BILL M | 12-028F | 10-035 | 0 | 195600 | 19560000 | 100 |  |  |  |  |  |  |  |  |  |  |  |  |  |  |  |  |  |  |  |  |  |  |  |  |  |  |
| 132113015 |  | Release Prcrmnt: Waveguide Parts (WVGUIDE COMPON) |  | 5d | 2010-02-08 A | 2010-02-15 A | 132113000 | 100% | 2010-02-08 | 2010-02-12 |  | ELEC ENG [8 h] | 530.16 | 530.16 | 0 | 530.16 | NELSON R | 1 | 1 | H | BILL M | 12-028F |  |  |  |  |  |  |  |  |  |  |  |  |  |  |  |  |  |  |  |  |  |  |  |  |  |  |  |  |  |  |  |
| 132113035 |  | Receive Responses, Evaluate, Award: Special Waveguide (WVGUIDE COMPON) |  | 5d | 2010-02-08 A | 2010-02-15 A | 132113015 | 100% | 2010-02-08 | 2010-02-12 |  | ELEC ENG [8 h] | 530.16 | 530.16 | 0 | 530.16 | NELSON R | 1 | 1 | H | BILL M | 12-028F |  |  |  |  |  |  |  |  |  |  |  |  |  |  |  |  |  |  |  |  |  |  |  |  |  |  |  |  |  |  |  |
| 132113040 |  | Receive Responses, Evaluate, Award: Waveguide Parts (WVGUIDE COMPON) |  | 5d | 2010-02-08 A | 2010-02-15 A | 132113020 | 100% | 2010-02-08 | 2010-02-12 |  | ELEC ENG [8 h] | 530.16 | 530.16 | 0 | 530.16 | NELSON R | 1 | 1 | H | BILL M | 12-028F |  |  |  |  |  |  |  |  |  |  |  |  |  |  |  |  |  |  |  |  |  |  |  |  |  |  |  |  |  |  |  |
| 132113065 |  | Receive,Test,Install Waveguide Compnts (P-#1, 4 zones) (WVGUIDE COMPON) Labor FY10 |  | 409d | 2010-02-08 A | 2011-09-26 A | 32-03M, 132113045, 132113050, 132113060, 132113055 | 100% |  |  |  | SUPPLIES & MATERIALS; MECH TECH [558.2 h]; ELEC ENG [12.4 h]; ELEC TECH [558.2 h]; ELEC DES [155.06 h] | 60,047 | 55,652.22 | 0 | 59009.2324 | NELSON R | 1 | 1 | S | BILL M | 12-028F | 10-035 |  |  |  |  | APP | 08-016 | 32113 | ST | Install | 09-012 | 11-001 |  |  |  |  |  |  |  |  |  |  |  |  |  |  |  |  |  |  |  |
| 132113065a |  | Receive,Test,Install Waveguide Compnts (P-#1, 4 zones) (WVGUIDE COMPON) Labor FY11 |  | 409d | 2010-02-08 A | 2011-09-26 A | 132113065 FS-178d | 100% | 2010-02-08 | 2011-09-27 |  | SUPPLIES & MATERIALS; MECH TECH [161.8 h]; ELEC ENG [3.6 h]; ELEC TECH [161.8 h]; ELEC DES [44.94 h] | 17,445.96 | 16,131.47 | 0 | 17649.383 | NELSON R | 1 | 1 | S | BILL M | 12-028F | 10-035 |  |  |  |  | APP | 08-016 | 32113 | ST | Install | 09-012 | 11-001 |  |  |  |  |  |  |  |  |  |  |  |  |  |  |  |  |  |  |  |
| 132113065b |  | Receive,Test,Install Waveguide Compnts (P-#1, 4 zones) (WVGUIDE COMPON) Procurement |  | 409d | 2010-02-08 A | 2011-09-26 A | 132113055, 132113045, 132113050, 132113060, 32-03M | 100% |  |  |  | PROCUREMENT>$50K 69 NO ESCALATION FY11 | 352,748.73 |  | 0 | 352748.73 | NELSON R | 1 | 1 | S | BILL M | 12-028F | 10-035 | 0 | 352748.73 | 35274873 | 100 | APP | 08-016 | 32113 | ST | Install | 09-012 | 11-001 |  |  |  |  |  |  |  |  |  |  |  |  |  |  |  |  |  |  |  |
| 132113055 |  | Receive First Special Waveguide (mfr delay) (WVGUIDE COMPON) |  | 1d | 2010-04-01 A | 2010-04-01 A | 132113035 | 100% |  |  |  |  |  |  |  | 0 | NELSON R | 1 | 1 | Z | BILL M | 12-028F |  |  |  |  |  |  |  |  |  |  |  |  |  |  |  |  |  |  |  |  |  |  |  |  |  |  |  |  |  |  |  |
| 132113060 |  | Receive First Waveguide Parts (mfr delay) (WVGUIDE COMPON) |  | 1d | 2010-04-01 A | 2010-04-01 A | 132113040 | 100% |  |  |  |  |  |  |  | 0 | NELSON R | 1 | 1 | Z | BILL M | 12-028F |  |  |  |  |  |  |  |  |  |  |  |  |  |  |  |  |  |  |  |  |  |  |  |  |  |  |  |  |  |  |  |
| 132113100 |  | Develop and Release Bid Package (40) HOM Filter (WVGUIDE COMPON) |  | 189d | 2010-04-26 A | 2011-01-31 A | 9-100M FS+143d | 100% |  |  |  | ELEC ENG [32 h] | 2,148.51 | 2,148.51 | 0 | 2120.64 | NELSON R | 1 | 1 | H | BILL M | 12-028F |  |  |  |  |  |  |  |  |  |  |  |  | 10-028 | 10-031 | 10-064 | 10-066 | 12-018F |  |  |  |  |  |  |  |  |  |  |  |  |  |  |
| 132113105 |  | Receive Responses, Evaluate, Award: (40) HOM Filters (WVGUIDE COMPON) |  | 39d | 2011-01-31 A | 2011-03-25 A | 132113100 FS+10d | 100% |  |  |  | ELEC ENG [40 h] | 2,735.2 | 2,735.2 | 0 | 2650.8 | NELSON R | 1 | 1 | H | BILL M | 12-028F |  |  |  |  |  |  |  |  |  |  |  |  | 10-028 | 10-031 | 10-064 | 10-066 | 12-018F |  |  |  |  |  |  |  |  |  |  |  |  |  |  |
| 132113075 |  | Receive,Test,Install Waveguide Compnts (P-#2, 4 zones) (WVGUIDE COMPON) Labor FY11 |  | 467d | 2011-03-01 A | 2013-05-13 A | 9-110M FS+60d, 132113070M FS-100d, 132113045G | 100% | 2011-03-01 | 2013-01-15 |  | MECH TECH [552.49 h]; ELEC TECH [552.49 h]; SUPPLIES & MATERIALS; ELEC DES [153.47 h] | 60,878.54 | 56,701.93 | 0 | 59428.4081 | NELSON R | 1 | 1 | S | BILL M | 12-028F | 10-035 |  |  |  |  | APP | 08-016 | 32113 | ST | Install | 09-012 |  |  |  |  |  |  | 12-001 | XX |  |  |  |  |  |  |  |  |  |  |  |  |
| 132113075a |  | Receive,Test,Install Waveguide Compnts (P-#2, 4 zones) (WVGUIDE COMPON) Labor FY12 |  | 467d | 2011-03-01 A | 2013-05-13 A | 132113075 FS-235d | 100% | 2011-03-01 | 2013-01-15 |  | ELEC DES [46.53 h]; MECH TECH [167.51 h]; SUPPLIES & MATERIALS; ELEC TECH [167.51 h] | 18,501.22 | 17,191.84 | 0 | 18591.441 | NELSON R | 1 | 1 | S | BILL M | 12-028F | 10-035 |  |  |  |  | APP | 08-016 | 32113 | ST |  | 09-012 |  |  |  |  |  |  | 12-001 | XX |  |  |  |  |  |  |  |  |  |  |  |  |
| 132113075b |  | Receive,Test,Install Waveguide Compnts (P-#2, 4 zones) (WVGUIDE COMPON) Procurement |  | 467d | 2011-03-01 A | 2013-05-13 A | 132113045G, 9-110M FS+60d, 132113070M FS-100d | 100% | 2011-03-01 | 2013-01-15 |  | PROCUREMENT<$50K 60 NO ESCALATION FY12; PROCUREMENT>$50K 69 NO ESCALATION FY12 | 365,213.48 |  | 0 | 365213.48 | NELSON R | 1 | 1 | S | BILL M | 12-028F | 10-035 | 0 | 365213.48 | 36521348 | 100 | APP | 08-016 | 32113 | ST |  | 09-012 |  |  |  |  |  |  | 12-001 | XX |  |  |  |  |  |  |  |  |  |  |  |  |
| 132113110 |  | Vend Fab (40) HOMs (manufacturing delay) (WVGUIDE COMPON) |  | 489d | 2011-03-01 A | 2013-04-15 A | 132113105 | 100% | 2011-03-01 | 2013-02-15 |  | PROCUREMENT<$50K 60; PROCUREMENT>$50K 69 | 309,570 |  | 0 | 309570 | NELSON R | 1 | 1 | D | BILL M | 12-028F |  | 0 | 309570 | 30957000 | 100 |  |  |  |  |  |  |  | 10-028 | 10-031 | 10-064 | 10-066 | 12-018F |  | XX | MP |  |  |  |  |  |  |  |  |  |  |  |
| 132113085a |  | Receive,Test,Install Waveguide Compnts (P-#3, 2 zones) (WVGUIDE COMPON) FY13 |  | 352d | 2011-09-12 A | 2013-07-15 A | 132113085 FS-120d | 100% | 2011-09-12 | 2013-02-14 |  | ELEC DES [54 h]; ELEC TECH [162 h]; MECH TECH [162 h]; SUPPLIES & MATERIALS | 18,312.08 | 17,290.6 | 0 | 18740.47 | NELSON R | 1 | 1 | S | BILL M | 12-028F |  |  |  |  |  | APP | 08-016 | 32113 | ST |  | 09-012 |  |  |  |  |  |  |  | XX |  | 12-053 |  |  |  |  |  |  |  |  |  |  |
| 132113085b |  | Receive,Test,Install Waveguide Compnts (P-#3, 2 zones) (WVGUIDE COMPON) Procurement |  | 352d | 2011-09-12 A | 2013-07-15 A | 132113080M FS-240d | 100% | 2011-09-12 | 2013-02-14 |  | PROCUREMENT>$50K 69 NO ESCALATION FY13; PROCUREMENT<$50K 60 NO ESCALATION FY13 | 296,795.4 |  | 0 | 296795.4 | NELSON R | 1 | 1 | S | BILL M | 12-028F |  | 0 | 296795.4 | 29679540 | 100 | APP | 08-016 | 32113 | ST |  | 09-012 |  |  |  |  |  |  |  | XX |  | 12-053 |  |  |  |  |  |  |  |  |  |  |
| 132113085 |  | FAB Receive,Test,Install Waveguide Compnts (P-#3, 2 zones) (WVGUIDE COMPON) |  | 352d | 2011-09-12 A | 2013-07-15 A | 132113080M FS-240d | 100% | 2011-09-12 | 2013-02-14 |  | ELEC DES [66 h]; MECH TECH [198 h]; SUPPLIES & MATERIALS; ELEC TECH [198 h] | 22,339.16 | 21,132.45 | 0 | 22196.14 | NELSON R | 1 | 1 | S | BILL M | 12-028F |  |  |  |  |  | APP | 08-016 | 32113 | ST | Install | 09-012 |  |  |  |  |  |  |  | XX |  | 12-053 | Split |  |  |  |  |  |  |  |  |  |
| 132113070M |  | End P-#1 Waveguide Installtn (WVGUIDE COMPON) | milestone | 0d | 2011-09-26 A | 2011-09-26 A | 132113065a, 132113065b | 100% | 2011-10-03 | 2011-10-03 |  |  |  |  |  | 0 | NELSON R | 1 | 1 | M | BILL M | 12-028F |  |  |  |  |  |  |  |  |  | Install |  |  |  |  |  |  |  |  |  |  |  |  | 6 |  |  |  |  |  |  |  |  |
| 132113115 |  | Receive and Inspect: (40) HOM Filters (WVGUIDE COMPON) |  | 316d | 2011-11-14 A | 2013-04-15 A | 132113110 FS-85d | 100% | 2011-11-14 | 2013-02-28 |  | ELEC TECH [80 h]; ELEC ENG [40 h] | 6,416.34 | 6,429.14 | 0 | 6156.8 | NELSON R | 1 | 1 | U | BILL M | 12-028F |  |  |  |  |  |  |  |  |  |  |  |  | 10-028 | 10-031 | 10-064 | 10-066 | 12-018F |  | XX |  |  |  |  |  |  |  |  |  |  |  |  |
| 132113130 |  | Klystron:Modify 20 tubes for body current problems |  | 21d | 2012-11-19 A | 2012-12-17 A | 9-130M FS+25d | 100% | 2012-11-19 | 2012-12-19 |  | ELEC TECH [40 h]; ELEC ENG [16 h] | 2,986.56 | 2,986.56 | 0 | 2986.56 | NELSON R | 1 | 1 | U | BILL M | 12-028F |  |  |  |  |  |  |  |  |  |  |  |  | 10-028 | 10-031 | 10-064 | 10-066 | 12-018F |  |  |  |  |  |  | 13-003 |  |  |  |  |  |  |  |
| 132113135 |  | Klystrons: Retune 20 tubes after Mods |  | 57d | 2012-12-03 A | 2012-12-17 A | 132113130 FS+72d | 100% | 2013-05-03 | 2013-07-24 |  | ELEC TECH [40 h]; ELEC ENG [64 h] | 6,481.44 | 6,481.44 | 0 | 6481.44 | NELSON R | 1 | 1 | U | BILL M | 12-028F |  |  |  |  |  |  |  |  |  |  |  |  | 10-028 | 10-031 | 10-064 | 10-066 | 12-018F |  |  |  |  |  |  | 13-003 |  |  |  |  |  |  |  |
| 132113120 |  | Remove SL Circulators for Repair |  | 26d | 2013-03-04 A | 2013-04-15 A | 9-130M FS+67d | 100% | 2013-04-01 | 2013-05-06 |  | ELEC TECH [140 h]; ELEC ENG [8 h] | 6,958.08 | 6,958.08 | 0 | 6958.08 | NELSON R | 1 | 1 | U | BILL M | 12-028F |  |  |  |  |  |  |  |  |  |  |  |  | 10-028 | 10-031 | 10-064 | 10-066 | 12-018F |  |  |  |  |  |  | 13-003 |  |  |  |  |  |  |  |
| 132113125 |  | Test and Reinstall SL Circulators |  | 62d | 2013-03-11 A | 2013-08-30 A | 132113120 FS-20d | 100% | 2013-05-02 | 2013-07-31 |  | ELEC TECH [220 h]; ELEC ENG [72 h] | 15,261.12 | 15,261.12 | 7020.1152 | 15261.12 | NELSON R | 1 | 1 | U | BILL M | 12-028F |  |  |  |  |  |  |  |  |  |  |  |  | 10-028 | 10-031 | 10-064 | 10-066 | 12-018F |  |  |  |  |  |  | 13-003 |  |  |  |  |  |  |  |
| 132113080M |  | End P-#2 Waveguide Installtn (WVGUIDE COMPON) | milestone | 0d | 2013-05-13 A | 2013-05-13 A | 132113075a, 132113075b | 100% | 2013-08-28 | 2013-08-28 |  |  |  |  |  | 0 | NELSON R | 1 | 1 | M | BILL M | 12-028F |  |  |  |  |  |  |  |  |  | Install |  |  |  |  |  |  |  |  | XX |  |  |  | 6 |  |  |  |  |  |  |  |  |
| 132113140 |  | Re-Baseline Actuals Adjustment |  | 1d | 2013-08-30 A | 2013-08-30 A |  | 100% | 2013-09-03 | 2013-09-03 |  | PROCUREMENT>$50K 69 NO ESCALATION | -623,864.83 |  |  |  |  |  |  |  |  |  |  |  |  |  | 100 |  |  |  |  |  |  |  |  |  |  |  |  |  |  |  |  |  |  |  | ADJ |  |  |  |  |  |  |
| 132113090M |  | Waveguide Installtn Comp (WVGUIDE COMPON) | milestone | 0d | 2013-08-30 A | 2013-08-30 A | 132113085b, 132113125, 132113085, 132113085a | 100% | 2013-09-06 | 2013-09-06 |  |  |  |  |  | 0 | NELSON R | 1 | 1 | M | BILL M | 12-028F |  |  |  |  |  |  |  |  |  | Install |  |  |  |  |  |  |  |  | XX |  |  |  | 6 |  |  |  |  |  |  |  |  |
| 232113125 |  | Test and Reinstall SL Circulators |  | 4d | 2013-09-03 A | 2013-09-06 A | 9-130M FS+228d | 100% | 2013-10-01 | 2013-10-04 | 8/5 M-F w/JLAB Holidays ReBaseline | ELEC TECH [11 h]; ELEC ENG [3.6 h] | 787.36 | 763.06 |  | 0 | NELSON R | 1 | 1 | H | BILL M | 12-028F |  |  |  |  |  |  |  |  |  |  |  |  | 10-028 | 10-031 | 10-064 | 10-066 | 12-018F |  |  |  |  |  |  | 13-003 |  | 232113125 | 763.056 | PE | PE | 13-015 | PR |

Notes:
- 132113065: Entry Criteria: Ext Pred: Machine in Maintenance SAD for access / Steps: Purchase & Install Long Waveguide Lenghts (done); Purchase, Test Dual Couplers (done); Purchase Sweeps (done); Purchase Flex (done); Install Waveguides, Zones 1-5 (upstairs) (done); Purchase Special Offsets & Flex (done); Purchase Long Flex (24') (done); Purchase Gaskets (done)
- 132113065a: Entry Criteria: Ext Pred: Machine in Maintenance SAD for access / Steps: Purchase & Install Long Waveguide Lenghts (done); Purchase, Test Dual Couplers (done); Purchase Sweeps (done); Purchase Flex (done); Install Waveguides, Zones 1-5 (upstairs) (done); Purchase Special Offsets & Flex (done); Purchase Long Flex (24') (done); Purchase Gaskets (done)
- 132113065b: Entry Criteria: Ext Pred: Machine in Maintenance SAD for access / Steps: Purchase & Install Long Waveguide Lenghts (done); Purchase, Test Dual Couplers (done); Purchase Sweeps (done); Purchase Flex (done); Install Waveguides, Zones 1-5 (upstairs) (done); Purchase Special Offsets & Flex (done); Purchase Long Flex (24') (done); Purchase Gaskets (done)
- 132113100: Entry Criteria: Ext Pred: Machine in Maint SAD for access
- 132113105: Entry Criteria: Ext Pred: Machine in Maint SAD for access
- 132113075: Entry Criteria: Ext Pred: Machine in Maint SAD for access / Steps: Install Waveguides, Zones 5-8 (downstairs) (done); Purchase Transitions (done); Purchase Tuners (done); Purchase Custom Straight Pieces (WG to cryomodules) (done); Purchase Offsets (done)
- 132113075a: Entry Criteria: Ext Pred: Machine in Maint SAD for access / Steps: Install Waveguides, Zones 5-8 (downstairs) (done); Purchase Transitions (done); Purchase Tuners (done); Purchase Custom Straight Pieces (WG to cryomodules) (done); Purchase Offsets (done)
- 132113075b: Entry Criteria: Ext Pred: Machine in Maint SAD for access / Steps: Install Waveguides, Zones 9-10 (downstairs) (done); Purchase Transitions (done); Purchase Tuners (done); Purchase Custom Straight Pieces (WG to cryomodules) (done); Purchase Offsets (done)
- 132113110: Entry Criteria: Ext Pred: Machine in Maint SAD for access
- 132113085a: Entry Criteria: Ext Pred: Machine in Maint SAD for access / Steps: Install Waveguides, Zones 9-10 (downstairs) (done); Purchase Transitions (done); Purchase Tuners (done); Purchase Custom Straight Pieces (WG to cryomodules) (done); Purchase Offsets (done)
- 132113085b: Entry Criteria: Ext Pred: Machine in Maint SAD for access / Steps: Install Waveguides, Zones 9-10 (downstairs) (done); Purchase Transitions (done); Purchase Tuners (done); Purchase Custom Straight Pieces (WG to cryomodules) (done); Purchase Offsets (done)
- 132113085: Entry Criteria: Ext Pred: Machine in Maint SAD for access / Steps: Install Waveguides, Zones 9-10 (downstairs) (done); Purchase Transitions (done); Purchase Tuners (done); Purchase Custom Straight Pieces (WG to cryomodules) (done); Purchase Offsets (done)
- 132113115: Entry Criteria: Ext Pred: Machine in Maint SAD for access
- 132113130: Entry Criteria: Ext Pred: Machine in Maint SAD for access
- 132113135: Entry Criteria: Ext Pred: Machine in Maint SAD for access
- 132113120: Entry Criteria: Ext Pred: Machine in Maint SAD for access
- 132113125: Entry Criteria: Ext Pred: Machine in Maint SAD for access
- 232113125: Entry Criteria: Ext Pred: Machine in Maint SAD for access

| ID | WBS | Activity | Type | Duration | Start | Finish | Predecessors | Complete | Planned start | Planned finish | Resources | Cost | Actual cost | Calculated Remaining Total Cost | MONTHLY EV COST | RESP - Responsibility | STRT%COMP for CM EVM | FNSH%COMP for CM EVM | CR 08-009 | EVMS Reporting Codes | CAM RESPONSIBLE | CR 09-012 | CR 10-031 | CR 10-064 | CR 10-066 | Remaining Material Cost Based on % Compl | Claimed Material Cost Based on % Complet | Initial Claimed Material Calc | Claimed Material Divider | Inter Project Link (IPL) | Milestone Level | CR 08-016 | CR 11-001 | CR 10-028 | CR 12-028 | CR 12-001 | Installation | CR 12-018 | CR 13-009 | MARCH!!! | ReBaseline Actuals Adjustment |
| --- | --- | --- | --- | --- | --- | --- | --- | --- | --- | --- | --- | --- | --- | --- | --- | --- | --- | --- | --- | --- | --- | --- | --- | --- | --- | --- | --- | --- | --- | --- | --- | --- | --- | --- | --- | --- | --- | --- | --- | --- | --- |
|  | 2 | **1.3.2.1.2 CONTROL** |  |  | 2009-07-24 | 2013-08-30 |  |  |  |  |  |  |  |  |  |  |  |  |  |  |  |  |  |  |  |  |  |  |  |  |  |  |  |  |  |  |  |  |  |  |  |
|  | 1 | **1.3.2.1.2.1 FIELD CONTROL (RF Items - All LLRF Labor)** |  |  | 2009-10-01 | 2013-08-30 |  |  |  |  |  |  |  |  |  |  |  |  |  |  |  |  |  |  |  |  |  |  |  |  |  |  |  |  |  |  |  |  |  |  |  |
| 132121000 |  | RF & Digital Bd Bid & Award (FIELD Control) |  | 41d | 2009-10-01 A | 2009-11-30 A | 9-100M, 1212121170, 1212121145M, 1212121095 | 100% |  |  | ELEC ENG [200 h]; ELEC DES [160 h]; OFFICE [40 h]; TRAVEL | 25,213.15 | 21,916.8 | 0 | 25213.152955 | HOVATER C | 1 | 1 | 08-009 | H | BILL M | 09-012 | 10-031 | 10-064 | 10-066 |  |  |  |  |  |  |  |  |  |  |  |  |  |  |  |  |
| 132121001 |  | RF & Digital Bd Vendor Fab (FIELD Control) |  | 199d | 2009-11-30 A | 2010-09-17 A | 9-100M, 132121000 | 100% |  |  | PROCUREMENT>$50K 69; PROCUREMENT<$50K 60 | 417,538.41 |  | 0 | 417538.40901 | HOVATER C | 1 | 1 | 08-009 | D | BILL M |  | 10-031 | 10-064 | 10-066 | 0 | 417538.40901 | 41753840.901 | 100 |  |  |  |  |  |  |  |  |  |  |  |  |
| 132121005 |  | First Article (RF and Digital) Inspection and Test (IPL 521215020M) |  | 63d | 2009-12-21 A | 2010-03-29 A | 1212125025M, 132121001 FS-200d | 100% | 2009-12-28 | 2010-03-29 | ELEC ENG [400 h]; ELEC DES [80 h]; ELEC TECH [80 h]; COMP SCIENT [320 h]; OFFICE [40 h]; SUPPLIES & MATERIALS | 61,211.48 | 54,410 | 0 | 61211.479918 | HOVATER C | 1 | 1 | 08-009 | H | BILL M |  | 10-031 | 10-064 | 10-066 |  |  |  |  | IPL |  |  |  |  |  |  |  |  |  |  |  |
| 132121020M |  | Comp First Article Board Testing (FIELD CONTROL) | milestone | 0d | 2010-03-29 A | 2010-03-29 A | 132121005 | 100% | 2010-04-01 | 2010-04-01 |  |  |  |  | 0 | HOVATER C | 1 | 1 | 08-009 | M | BILL M |  | 10-031 | 10-064 | 10-066 |  |  |  |  |  | 6 |  |  |  |  |  |  |  |  |  |  |
| 132121045 |  | First FC Chassis Tested (FIELD Control) Labor FY10 |  | 84d | 2010-03-29 A | 2010-07-26 A | 132121010 FS-500d, 132121035M FS-500d | 100% |  |  | ELEC ENG [216.47 h]; ELEC DES [86.59 h]; ELEC TECH [86.59 h]; OFFICE [21.65 h]; COMP SCIENT [173.18 h] | 33,294.25 | 33,294.25 | 0 | 33294.2401 | HOVATER C | 1 | 1 | 08-009 | U | BILL M | 09-012 | 10-031 | 10-064 | 10-066 |  |  |  |  |  |  | 08-016 | 11-001 |  |  |  |  |  |  |  |  |
| 132121045a |  | First FC Chassis Tested (FIELD Control) Labor FY11 |  | 84d | 2010-03-29 A | 2010-07-26 A | 132121035M FS-500d, 132121010 FS-500d | 100% |  |  | OFFICE [18.35 h]; COMP SCIENT [146.82 h]; ELEC ENG [183.53 h]; ELEC DES [73.41 h]; ELEC TECH [73.41 h] | 28,226.95 | 28,226.95 | 0 | 29126.9749 | HOVATER C | 1 | 1 | 08-009 | U | BILL M | 09-012 | 10-031 | 10-064 | 10-066 |  |  |  |  |  |  | 08-016 | 11-001 |  |  |  |  |  |  |  |  |
| 132121045b |  | First FC Chassis Tested (FIELD Control) Procurement |  | 84d | 2010-03-29 A | 2010-07-26 A | 132121035M FS-500d, 132121010 FS-500d | 100% |  |  | PROCUREMENT<$50K 60 NO ESCALATION FY11 | 10,987.86 |  | 0 | 10987.856942 | HOVATER C | 1 | 1 | 08-009 | U | BILL M | 09-012 | 10-031 | 10-064 | 10-066 | 0 | 10987.856942 | 1098785.6942 | 100 |  |  | 08-016 | 11-001 |  |  |  |  |  |  |  |  |
| 132121010 |  | RF Boards Inspection and Testing |  | 247d | 2010-05-03 A | 2011-04-29 A | 132121005 FS+9d | 100% |  |  | ELEC DES [160 h]; ELEC TECH [400 h]; COMP SCIENT [80 h]; OFFICE [80 h]; SUPPLIES & MATERIALS; ELEC ENG [600 h] | 77,967.8 | 72,298.07 | 0 | 76676.533274 | HOVATER C | 1 | 1 | 08-009 | U | BILL M |  | 10-031 | 10-064 | 10-066 |  |  |  |  |  |  |  |  |  |  |  |  |  |  |  |  |
| 132121025 |  | Digital Boards Inspection and Testing |  | 222d | 2010-05-03 A | 2011-03-25 A | 132121005, 132121020M FS+9d | 100% |  |  | ELEC DES [80 h]; COMP SCIENT [240 h]; ELEC ENG [400 h]; ELEC TECH [240 h] | 55,956.72 | 55,956.72 | 0 | 55040 | HOVATER C | 1 | 1 | 08-009 | U | BILL M |  | 10-031 | 10-064 | 10-066 |  |  |  |  |  |  |  |  |  |  |  |  |  |  |  |  |
| 132121040 |  | FC Chassis Procure and Fabricate Labor FY10 |  | 211.51d | 2010-05-17 A | 2011-03-25 A | 9-110M FS-120d, 132121010 FS-85d | 100% |  |  | OFFICE [18.21 h]; COMP SCIENT [36.41 h]; ELEC ENG [36.41 h]; ELEC DES [72.83 h]; ELEC TECH [728.28 h] | 39,461.69 | 39,496.95 | 0 | 38786.9462 | HOVATER C | 1 | 1 | 08-009 | U | BILL M | 09-012 | 10-031 | 10-064 | 10-066 |  |  |  |  |  |  | 08-016 | 11-001 | 10-028 | 12-028F |  |  |  |  |  |  |
| 132121040a |  | FC Chassis Procure and Fabricate Labor FY11 |  | 212d | 2010-05-17 A | 2011-03-25 A | 132121010 FS-85d, 9-110M FS-120d | 100% |  |  | COMP SCIENT [43.59 h]; ELEC ENG [43.59 h]; ELEC DES [87.17 h]; OFFICE [21.79 h]; ELEC TECH [871.72 h] | 47,236.26 | 47,236.26 | 0 | 47905.9375 | HOVATER C | 1 | 1 | 08-009 | U | BILL M | 09-012 | 10-031 | 10-064 | 10-066 |  |  |  |  |  |  | 08-016 | 11-001 | 10-028 | 12-028F |  |  |  |  |  |  |
| 132121040b |  | FC Chassis Procure and Fabricate Procurement |  | 212d | 2010-05-17 A | 2011-03-25 A | 9-110M FS-120d, 132121010 FS-85d | 100% |  |  | PROCUREMENT<$50K 60 NO ESCALATION FY11 | 103,285.82 |  | 0 | 103285.82223 | HOVATER C | 1 | 1 | 08-009 | U | BILL M | 09-012 | 10-031 | 10-064 | 10-066 | 0 | 103285.82223 | 10328582.223 | 100 |  |  | 08-016 | 11-001 | 10-028 | 12-028F |  |  |  |  |  |  |
| 132121055 |  | FC Chassis Bench Testing (FIELD Control) Labor FY11 |  | 322.77d | 2010-11-22 A | 2012-03-19 A | 132121040 FS-200d, 132121040b FS-200d, 3A-02M FS-120d, 132125020 FS-120d, 132121040a FS-200d, 32-03M | 100% |  |  | ELEC DES [193.77 h]; ELEC TECH [484.43 h]; OFFICE [48.44 h]; ELEC ENG [242.21 h]; COMP SCIENT [48.44 h] | 51,746.47 | 51,746.48 | 0 | 51187.0668 | HOVATER C | 1 | 1 | 08-009 | U | BILL M | 09-012 | 10-031 | 10-064 | 10-066 |  |  |  |  |  |  | 08-016 |  | 10-028 | 12-028F | 12-001 |  |  |  |  |  |
| 132121055a |  | FC Chassis Bench Testing (FIELD Control) Labor FY12 |  | 323d | 2010-11-22 A | 2012-03-19 A | 132121055 FS-120d | 100% |  |  | ELEC ENG [157.79 h]; COMP SCIENT [31.56 h]; ELEC DES [126.23 h]; ELEC TECH [315.57 h]; OFFICE [31.56 h] | 33,710.67 | 33,710.67 | 0 | 34407.649 | HOVATER C | 1 | 1 | 08-009 | U | BILL M | 09-012 | 10-031 | 10-064 | 10-066 |  |  |  |  |  |  | 08-016 |  | 10-028 | 12-028F | 12-001 |  |  |  |  |  |
| 132121055b |  | FC Chassis Bench Testing (FIELD Control) Procurement |  | 323d | 2010-11-22 A | 2012-03-19 A | 132121040b FS-200d, 132121040 FS-200d, 132125020 FS-120d, 132121040a FS-200d, 3A-02M FS-120d, 32-03M | 100% |  |  | PROCUREMENT<$50K 60 NO ESCALATION FY12 | 11,338.37 |  | 0 | 11338.37 | HOVATER C | 1 | 1 | 08-009 | U | BILL M | 09-012 | 10-031 | 10-064 | 10-066 | 0 | 11338.37 | 1133837 | 100 |  |  | 08-016 |  | 10-028 | 12-028F | 12-001 |  |  |  |  |  |
| 132121030M |  | 1/2 Production Boards Tested (FIELD CONTROL) | milestone | 0d | 2010-11-23 A | 2010-11-23 A | 132121025 FS-22d, 132121005 | 100% | 2010-12-30 | 2010-12-30 |  |  |  |  | 0 | HOVATER C | 1 | 1 | 08-009 | M | BILL M |  | 10-031 | 10-064 | 10-066 |  |  |  |  |  | 6 |  |  |  |  |  |  |  |  |  |  |
| 132121035M |  | Comp Production Board Testing (FIELD CONTROL) | milestone | 0d | 2011-04-29 A | 2011-04-29 A | 132121030M, 132121025 | 100% | 2011-05-02 | 2011-05-02 |  |  |  |  | 0 | HOVATER C | 1 | 1 | 08-009 | M | BILL M |  | 10-031 | 10-064 | 10-066 |  |  |  |  |  | 6 |  |  |  |  |  |  |  |  |  |  |
| 132121060 |  | Zone Test & Check (FIELD Control) Labor FY11 Frozen Per CR12-028 |  | 197.71d | 2011-05-23 A | 2012-03-12 A | 132121055b FS-205d, 132121055 FS-205d, 132121045a, 132121055a FS-205d, 132121045b, 132121045 | 100% |  |  | SUPPLIES & MATERIALS; ELEC TECH [147.27 h]; COMP SCIENT [133.88 h]; SCIENTIST [40.17 h]; ELEC DES [133.88 h]; ELEC ENG [133.88 h] | 35,555.23 | 33,836.07 | 0 | 34988.3006 | HOVATER C | 1 | 1 | 08-009 | U | BILL M | 09-012 | 10-031 | 10-064 | 10-066 |  |  |  |  | IPL |  | 08-016 |  | 10-028 | 12-028F | 12-001 |  |  |  |  |  |
| 132121060a |  | Zone Test & Check (FIELD Control) Labor FY12 Frozen Per CR12-028 |  | 198d | 2011-05-23 A | 2012-03-12 A | 132121060 FS-160d | 100% |  |  | ELEC TECH [178.18 h]; COMP SCIENT [161.99 h]; SCIENTIST [48.59 h]; ELEC DES [161.99 h]; ELEC ENG [161.99 h]; SUPPLIES & MATERIALS | 43,086.16 | 40,939.83 | 0 | 43682.2664 | HOVATER C | 1 | 1 | 08-009 | U | BILL M | 09-012 | 10-031 | 10-064 | 10-066 |  |  |  |  | IPL |  | 08-016 |  | 10-028 | 12-028 | 12-001 |  |  |  |  |  |
| 132121060b |  | Zone Test & Check (FIELD Control) Procurement Frozen Per CR12-028 |  | 198d | 2011-05-23 A | 2012-03-12 A | 132121055b FS-205d, 132121045, 132121045b, 132121055 FS-205d, 132121045a, 132121055a FS-205d | 100% |  |  | PROCUREMENT<$50K 60 NO ESCALATION FY12 | 5,102.27 |  | 0 | 5102.27 | HOVATER C | 1 | 1 | 08-009 | D | BILL M | 09-012 | 10-031 | 10-064 | 10-066 | 0 | 5102.27 | 510227 | 100 | IPL |  | 08-016 |  | 10-028 | 12-028 | 12-001 |  |  |  |  |  |
| 132121061M |  | First Zone Installed/Tested (FIELD CONTROL) | milestone | 0d | 2011-06-30 A | 2011-06-30 A | 132121060a FS-226d, 132121060b FS-226d | 100% | 2011-08-02 | 2011-08-02 |  |  |  |  | 0 | HOVATER C | 1 | 1 | 08-009 | M | BILL M |  | 10-031 | 10-064 | 10-066 |  |  |  |  |  | 6 |  |  | 10-028 | 12-028 |  | Install |  |  |  |  |
| 132121062M |  | Second Zone Installed/Tested (FIELD CONTROL) | milestone | 0d | 2011-07-18 A | 2011-07-18 A | 132121061M FS+20d | 100% | 2011-08-01 | 2011-08-01 |  |  |  |  | 0 | HOVATER C | 1 | 1 | 08-009 | M | BILL M |  | 10-031 | 10-064 | 10-066 |  |  |  |  |  | 6 |  |  | 10-028 | 12-028 |  | Install |  |  |  |  |
| 132121063M |  | Third Zone Installed/Tested (FIELD CONTROL) | milestone | 0d | 2011-09-15 A | 2011-09-15 A | 132121062M FS+62d | 100% | 2011-10-03 | 2011-10-03 |  |  |  |  | 0 | HOVATER C | 1 | 1 | 08-009 | M | BILL M |  | 10-031 | 10-064 | 10-066 |  |  |  |  |  | 6 |  |  | 10-028 | 12-028 |  | Install | 12-018F |  |  |  |
| 132121064M |  | Fourth Zone Installed/Tested (FIELD CONTROL) | milestone | 0d | 2012-01-16 A | 2012-01-16 A | 132121063M | 100% | 2012-01-31 | 2012-01-31 |  |  |  |  | 0 | HOVATER C | 1 | 1 | 08-009 | M | BILL M |  | 10-031 | 10-064 | 10-066 |  |  |  |  |  | 6 |  |  | 10-028 | 12-028 |  | Install | 12-018F |  |  |  |
| 132121060f |  | Reverse Entry Per CR12-028 |  | 8d | 2012-03-01 A | 2012-03-12 A | 9-120M FS+100d | 100% |  |  | ELEC TECH [-125 h]; COMP SCIENT [-114 h]; SCIENTIST [-33 h]; ELEC DES [-114 h]; ELEC ENG [-114 h]; SUPPLIES & MATERIALS | -30,632.04 | -29,129.04 |  |  | HOVATER C | 1 | 1 | 08-009 | Z | BILL M | 09-012 | 10-031 | 10-064 | 10-066 |  |  |  |  | IPL |  | 08-016 |  | 10-028 | 12-028 | 12-001 |  |  |  |  |  |
| 132121050M |  | Comp FC Bench Testing (FIELD CONTROL) | milestone | 0d | 2012-03-27 A | 2012-03-27 A | 132121055b FS+7d, 132121055 FS+7d, 132121055a FS+7d | 100% | 2012-04-02 | 2012-04-02 |  |  |  |  | 0 | HOVATER C | 1 | 1 | 08-009 | M | BILL M |  |  | 10-064 | 10-066 |  |  |  |  |  | 6 |  |  | 10-028 | 12-028F |  |  |  | 13-009F |  |  |
| 132121060c |  | Zone Test & Check (FIELD Control) Labor Revised Per CR12-028 |  | 91d | 2012-10-01 A | 2013-07-15 A | 9-130M | 100% | 2012-10-01 | 2013-02-15 | SCIENTIST [65.8 h]; ELEC DES [219.33 h]; ELEC ENG [219.33 h]; SUPPLIES & MATERIALS; ELEC TECH [241.27 h]; COMP SCIENT [219.33 h] | 61,010.3 | 58,033.36 | 0 | 61010.295 | HOVATER C | 1 | 1 | 08-009 | U | BILL M | 09-012 | 10-031 | 10-064 | 10-066 |  |  |  |  | IPL |  | 08-016 |  | 10-028 | 12-028 | 12-001 |  |  | 13-009F | XX |  |
| 132121060d |  | Zone Test & Check (FIELD Control) Procurement Revised Per CR12-028 |  | 99d | 2012-10-01 A | 2013-07-15 A | 9-130M | 100% | 2012-10-01 | 2013-02-28 | PROCUREMENT<$50K 60 | 6,435.03 |  | 0 | 6435.03 | HOVATER C | 1 | 1 | 08-009 | D | BILL M | 09-012 | 10-031 | 10-064 | 10-066 | 0 | 6435.03 | 643503 | 100 | IPL |  | 08-016 |  | 10-028 | 12-028 | 12-001 |  |  | 13-009F | XX |  |
| 132121065M |  | Fifth Zone Installed/Tested (FIELD CONTROL) | milestone | 0d | 2012-10-30 A | 2012-10-30 A | 132121060c FS-70d, 132121064M FS+17d, 132123020M | 100% | 2012-12-04 | 2012-12-04 |  |  |  |  | 0 | HOVATER C | 1 | 1 | 08-009 | M | BILL M |  | 10-031 | 10-064 | 10-066 |  |  |  |  |  | 6 |  |  | 10-028 | 12-028 |  | Install | 12-018F | 13-009F |  |  |
| 132121066M |  | Sixth Zone Installed/Tested (FIELD CONTROL) | milestone | 0d | 2013-01-28 A | 2013-01-28 A | 132121065M FS+22d | 100% | 2013-02-01 | 2013-02-01 |  |  |  |  | 0 | HOVATER C | 1 | 1 | 08-009 | M | BILL M |  | 10-031 | 10-064 | 10-066 |  |  |  |  |  | 6 |  |  | 10-028 | 12-028 |  | Install | 12-018F | 13-009F | XX |  |
| 132121067M |  | Seventh Zone Installed/Tested (FIELD CONTROL) | milestone | 0d | 2013-01-28 A | 2013-01-28 A | 132121066M FS+10d | 100% | 2013-02-14 | 2013-02-14 |  |  |  |  | 0 | HOVATER C | 1 | 1 | 08-009 | M | BILL M |  | 10-031 | 10-064 | 10-066 |  |  |  |  |  | 6 |  |  | 10-028 | 12-028 |  | Install | 12-018F | 13-009F | XX |  |
| 132121068M |  | Eighth Zone Installed/Tested (FIELD CONTROL) | milestone | 0d | 2013-02-20 A | 2013-02-20 A | 132121067M FS+16d | 100% | 2013-03-01 | 2013-03-01 |  |  |  |  | 0 | HOVATER C | 1 | 1 | 08-009 | M | BILL M |  |  | 10-064 | 10-066 |  |  |  |  |  | 6 |  |  | 10-028 | 12-028 |  | Install | 12-018F | 13-009F | XX |  |
| 132121069M |  | Ninth Zone Installed/Tested (FIELD CONTROL) | milestone | 0d | 2013-03-07 A | 2013-03-07 A | 132121068M FS+12d | 100% | 2013-04-01 | 2013-04-01 |  |  |  |  | 0 | HOVATER C | 1 | 1 | 08-009 | M | BILL M |  |  | 10-064 | 10-066 |  |  |  |  |  | 6 |  |  | 10-028 | 12-028 |  | Install |  | 13-009F | XX |  |
| 132121070M |  | Tenth Zone Installed/Tested (FIELD CONTROL) | milestone | 0d | 2013-04-15 A | 2013-04-15 A | 132121069M, 132121050M, 132123025M, 132121060c, 132121060a, 132121060b, 132121060d FS-10d | 100% | 2013-06-14 | 2013-06-14 |  |  |  |  | 0 | HOVATER C | 1 | 1 | 08-009 | M | BILL M |  |  | 10-064 | 10-066 |  |  |  |  |  | 6 |  |  | 10-028 | 12-028 |  | Install |  | 13-009F | XX |  |
| 132121075 |  | Re-Baseline Actuals Adjustment |  | 1d | 2013-08-30 A | 2013-08-30 A |  | 100% | 2013-09-03 | 2013-09-03 | PROCUREMENT>$50K 69 NO ESCALATION | -271,295.32 |  |  |  |  |  |  |  |  |  |  |  |  |  |  |  |  | 100 |  |  |  |  |  |  |  |  |  |  |  | ADJ |

Notes:
- 132121060a: Explanation: IPL from 6 GeV / 53216025M
- 132121060b: Explanation: IPL from 6 GeV / 53216025M
- 132121061M: Explanation: Added 1 week lag between Milestones for / Integrated "Test into Shorts" 01Feb2011 PMC
- 132121062M: Explanation: Added 1 week lag between Milestones for / Integrated "Test into Shorts" 01Feb2011 PMC
- 132121063M: Explanation: Added 1 week lag between Milestones for / Integrated "Test into Shorts" 01Feb2011 PMC
- 132121064M: Explanation: Added 1 week lag between Milestones for / Integrated "Test into Shorts" 01Feb2011 PMC
- 132121060f: Explanation: IPL from 6 GeV / 53216025M
- 132121060c: Explanation: IPL from 6 GeV / 53216025M
- 132121060d: Explanation: IPL from 6 GeV / 53216025M
- 132121065M: Explanation: Added 1 week lag between Milestones for / Integrated "Test into Shorts" 01Feb2011 PMC
- 132121066M: Explanation: Added 1 week lag between Milestones for / Integrated "Test into Shorts" 01Feb2011 PMC
- 132121067M: Explanation: Added 1 week lag between Milestones for / Integrated "Test into Shorts" 01Feb2011 PMC
- 132121068M: Explanation: Added 1 week lag between Milestones for / Integrated "Test into Shorts" 01Feb2011 PMC
- 132121069M: Explanation: Added 1 week lag between Milestones for / Integrated "Test into Shorts" 01Feb2011 PMC
- 132121070M: Explanation: Added 1 week lag between Milestones for / Integrated "Test into Shorts" 01Feb2011 PMC

| ID | WBS | Activity | Type | Duration | Start | Finish | Predecessors | Complete | Planned start | Planned finish | Resources | Cost | Actual cost | Calculated Remaining Total Cost | MONTHLY EV COST | RESP - Responsibility | STRT%COMP for CM EVM | FNSH%COMP for CM EVM | CR 08-009 | CR 08-016 | EVMS Reporting Codes | CAM RESPONSIBLE | CR 09-012 | CR 10-028 | CR 10-031 | CR 10-064 | CR 10-066 | CR 11-001 | Remaining Material Cost Based on % Compl | Claimed Material Cost Based on % Complet | Initial Claimed Material Calc | Claimed Material Divider | Activities with Steps | CR 12-001 | CR 12-018 | CR 12-028 | Milestone Level | Installation | MARCH!!! | ReBaseline Actuals Adjustment |
| --- | --- | --- | --- | --- | --- | --- | --- | --- | --- | --- | --- | --- | --- | --- | --- | --- | --- | --- | --- | --- | --- | --- | --- | --- | --- | --- | --- | --- | --- | --- | --- | --- | --- | --- | --- | --- | --- | --- | --- | --- |
|  | 2 | **1.3.2.1.2.2 RESONANCE CONTROL & INTERLOCKS (Interlocks,Tuner Controls)** |  |  | 2009-07-24 | 2013-08-30 |  |  |  |  |  |  |  |  |  |  |  |  |  |  |  |  |  |  |  |  |  |  |  |  |  |  |  |  |  |  |  |  |  |  |
| 132122000 |  | Bid & Award Matrl & Parts (RESON CTRL) FY10 |  | 313d | 2009-07-24 A | 2010-10-25 A | 1212122110M, 1212122170 | 100% |  |  | ELEC ENG [38 h]; TRAVEL; ELEC DES [76 h]; OFFICE [25.33 h] | 7,478.35 | 6,782.45 | 0 | 7498.6973 | HOVATER C | 1 | 1 | 08-009 | 08-016 | H | BILL M | 09-012 | 10-028 | 10-031 | 10-064 | 10-066 | 11-001 |  |  |  |  |  |  |  |  |  |  |  |  |
| 132122000a |  | Bid & Award Matrl & Parts (RESON CTRL) FY11 |  | 347.2d | 2009-07-24 A | 2010-12-15 A | 132122000 FS-60d | 100% |  |  | TRAVEL; ELEC DES [164 h]; OFFICE [54.67 h]; ELEC ENG [82 h] | 16,236.04 | 14,686.46 | 0 | 16697.2589 | HOVATER C | 1 | 1 | 08-009 | 08-016 | H | BILL M | 09-012 | 10-028 | 10-031 | 10-064 | 10-066 | 11-001 |  |  |  |  |  |  |  |  |  |  |  |  |
| 132122001 |  | Vend Fab Matrl & Parts (RESON CTRL) |  | 283d | 2009-10-26 A | 2010-12-15 A | 132122000a FS-1000d | 100% |  |  | PROCUREMENT<$50K 60; PROCUREMENT>$50K 69 | 198,421.39 |  | 0 | 198421.39 | HOVATER C | 1 | 1 | 08-009 |  | S | BILL M |  | 10-028 | 10-031 | 10-064 | 10-066 |  | 0 | 198421.39 | 19842139 | 100 | ST |  |  |  |  |  |  |  |
| 132122005 |  | Fab & Test Stepper Chassis (RESON CTRL) |  | 125d | 2009-11-23 A | 2010-05-31 A | 9-120M FS-500d, 132122001 FS-500d | 100% | 2009-11-23 | 2010-05-28 | ELEC ENG [200 h]; ELEC DES [240 h]; ELEC TECH [920 h]; COMP SCIENT [80 h]; PROCUREMENT<$50K 60 | 90,379.92 | 67,703.2 | 0 | 92536.32 | HOVATER C | 1 | 1 | 08-009 |  | U | BILL M |  | 10-028 | 10-031 | 10-064 | 10-066 |  | 0 | 22676.72 | 2267672 | 100 |  |  |  |  |  |  |  |  |
| 132122010 |  | Fab & Test PZT Chassis (RESON CTRL) Phase 1 |  | 152.19d | 2010-01-25 A | 2010-08-30 A | 9-120M FS-500d | 100% |  |  | ELEC ENG [96 h]; ELEC DES [96 h]; ELEC TECH [368 h]; COMP SCIENT [32 h]; PROCUREMENT<$50K 60 | 36,931.88 | 28,141.6 | 0 | 36931.88 | HOVATER C | 1 | 1 | 08-009 |  | U | BILL M |  | 10-028 | 10-031 | 10-064 | 10-066 |  | 0 | 8790.28 | 879028 | 100 |  |  |  |  |  |  |  |  |
| 132122015 |  | Fab & Test Heater & Interlock (RESON CTRL) Labor FY10 |  | 274.44d | 2010-05-24 A | 2011-06-30 A | 9-100M FS+163d | 100% |  |  | ELEC ENG [130.05 h]; ELEC DES [148.63 h]; ELEC TECH [427.32 h] | 34,092.29 | 34,092.29 | 0 | 33381.8347 | HOVATER C | 1 | 1 | 08-009 |  | U | BILL M |  | 10-028 | 10-031 | 10-064 | 10-066 | 11-001 |  |  |  |  |  |  |  |  |  |  |  |  |
| 132122015a |  | Fab & Test Heater & Interlock (RESON CTRL) Labor FY11 |  | 274.22d | 2010-05-24 A | 2011-06-30 A | 9-100M FS+163d | 100% |  |  | ELEC ENG [149.95 h]; ELEC DES [171.37 h]; ELEC TECH [492.68 h] | 39,307.38 | 39,307.38 | 0 | 39714.0661 | HOVATER C | 1 | 1 | 08-009 |  | U | BILL M |  | 10-028 | 10-031 | 10-064 | 10-066 | 11-001 |  |  |  |  |  |  |  |  |  |  |  |  |
| 132122015b |  | Fab & Test Heater & Interlock (RESON CTRL) Procurement |  | 275d | 2010-05-24 A | 2011-06-30 A | 9-100M FS+163d | 100% |  |  | PROCUREMENT<$50K 60 NO ESCALATION FY11 | 21,975.7 |  | 0 | 21975.7 | HOVATER C | 1 | 1 | 08-009 |  | U | BILL M |  | 10-028 | 10-031 | 10-064 | 10-066 | 11-001 | 0 | 21975.703565 | 2197570.3565 | 100 |  |  |  |  |  |  |  |  |
| 132122010a |  | Fab & Test PZT Chassis (RESON CTRL) Phase 2 Labor FY10 |  | 14d | 2010-08-30 A | 2010-09-17 A | 132122010 | 100% |  |  | ELEC DES [69.25 h]; ELEC TECH [265.47 h]; COMP SCIENT [23.08 h]; ELEC ENG [69.25 h] | 20,300.34 | 20,300.34 | 0 | 20300.3386 | HOVATER C | 1 | 1 | 08-009 |  | U | BILL M |  | 10-028 | 10-031 | 10-064 | 10-066 | 11-001 |  |  |  |  |  |  |  |  |  |  |  |  |
| 132122010b |  | Fab & Test PZT Chassis (RESON CTRL) Phase 2 Labor FY11 |  | 14d | 2010-08-30 A | 2010-09-17 A | 132122010 | 100% |  |  | ELEC TECH [286.53 h]; COMP SCIENT [24.92 h]; ELEC ENG [74.75 h]; ELEC DES [74.75 h] | 21,912.06 | 21,912.06 | 0 | 22609.9684 | HOVATER C | 1 | 1 | 08-009 |  | U | BILL M |  | 10-028 | 10-031 | 10-064 | 10-066 | 11-001 |  |  |  |  |  |  |  |  |  |  |  |  |
| 132122010c |  | Fab & Test PZT Chassis (RESON CTRL) Phase 2 Procurement |  | 14d | 2010-08-30 A | 2010-09-17 A | 132122010 | 100% |  |  | PROCUREMENT<$50K 60 NO ESCALATION FY11 | 43 |  | 0 | 43 | HOVATER C | 1 | 1 | 08-009 |  | U | BILL M |  | 10-028 | 10-031 | 10-064 | 10-066 | 11-001 | 0 | 43 | 4300 | 100 |  |  |  |  |  |  |  |  |
| 132122020 |  | Zone Test and Check (Reson Ctrl) Labor FY11 Frozen Per CR12-028 |  | 203d | 2011-05-16 A | 2012-03-12 A | 132122015 FS-25d, 132122015a FS-25d, 132122015b FS-25d | 100% |  |  | SUPPLIES & MATERIALS; ELEC TECH [223.11 h]; COMP SCIENT [89.24 h]; ELEC ENG [66.93 h]; ELEC DES [89.24 h] | 31,255.07 | 24,564.08 | 0 | 30853.1477 | HOVATER C | 1 | 1 | 08-009 | 08-016 | U | BILL M | 09-012 | 10-028 | 10-031 | 10-064 | 10-066 |  |  |  |  |  |  | 12-001 | 12-018F | 12-028 |  |  |  |  |
| 132122020a |  | Zone Test and Check (Reson Ctrl) Labor FY12 Frozen Per CR12-028 |  | 203d | 2011-05-16 A | 2012-03-12 A | 132122020 FS-120d | 100% |  |  | ELEC DES [62.47 h]; ELEC TECH [156.17 h]; COMP SCIENT [62.47 h]; SUPPLIES & MATERIALS; ELEC ENG [46.85 h] | 22,027.8 | 17,194.7 | 0 | 22285.2592 | HOVATER C | 1 | 1 | 08-009 | 08-016 | U | BILL M | 09-012 | 10-028 | 10-031 | 10-064 | 10-066 |  |  |  |  |  |  | 12-001 | 12-018F | 12-028 |  |  |  |  |
| 132122020b |  | Zone Test and Check (Reson Ctrl) Procurement Frozen Per CR12-028 |  | 203d | 2011-05-16 A | 2012-03-12 A | 132122015b FS-25d, 132122015a FS-25d, 132122015 FS-25d | 100% |  |  | PROCUREMENT<$50K 60 NO ESCALATION FY12 | 11,338.37 |  | 0 | 11338.37 | HOVATER C | 1 | 1 | 08-009 | 08-016 | D | BILL M | 09-012 | 10-028 | 10-031 | 10-064 | 10-066 |  | 0 | 11338.37 | 1133837 | 100 |  | 12-001 | 12-018F | 12-028 |  |  |  |  |
| 132122021M |  | First Zone Installed/Tested (RESON CTRL) | milestone | 0d | 2011-08-15 A | 2011-08-15 A | 132122020b FS-195d, 132122010, 132122020a FS-195d | 100% | 2011-09-15 | 2011-09-15 |  |  |  |  | 0 | HOVATER C | 1 | 1 | 08-009 |  | M | BILL M |  | 10-028 | 10-031 | 10-064 | 10-066 |  |  |  |  |  |  |  | 12-018F | 12-028F | 6 | Install |  |  |
| 132122022M |  | Second Zone Installed/Tested (RESON CTRL) | milestone | 0d | 2011-09-19 A | 2011-09-19 A | 132122021M FS+35d | 100% | 2011-10-03 | 2011-10-03 |  |  |  |  | 0 | HOVATER C | 1 | 1 | 08-009 |  | M | BILL M |  | 10-028 | 10-031 | 10-064 | 10-066 |  |  |  |  |  |  |  | 12-018F | 12-028F | 6 | Install |  |  |
| 132122023M |  | Third Zone Installed/Tested (RESON CTRL) | milestone | 0d | 2011-11-01 A | 2011-11-01 A | 132122022M FS+40d | 100% | 2011-12-01 | 2011-12-01 |  |  |  |  | 0 | HOVATER C | 1 | 1 | 08-009 |  | M | BILL M |  | 10-028 | 10-031 | 10-064 | 10-066 |  |  |  |  |  |  |  | 12-018F | 12-028F | 6 | Install |  |  |
| 132122024M |  | Fourth Zone Installed/Tested (RESON CTRL) | milestone | 0d | 2012-01-16 A | 2012-01-16 A | 132122023M FS+40d | 100% | 2012-01-31 | 2012-01-31 |  |  |  |  | 0 | HOVATER C | 1 | 1 | 08-009 |  | M | BILL M |  | 10-028 | 10-031 | 10-064 | 10-066 |  |  |  |  |  |  |  | 12-018F | 12-028F | 6 | Install |  |  |
| 132122020f |  | Reverse Entry Per CR12-028 |  | 8d | 2012-03-01 A | 2012-03-12 A | 9-120M FS+100d | 100% |  |  | COMP SCIENT [-78 h]; SUPPLIES & MATERIALS; ELEC ENG [-58 h]; ELEC DES [-78 h]; ELEC TECH [-198 h] | -27,896.2 | -21,888.36 |  |  | HOVATER C | 1 | 1 | 08-009 | 08-016 | Z | BILL M | 09-012 | 10-028 | 10-031 | 10-064 | 10-066 |  |  |  |  |  |  | 12-001 | 12-018F | 12-028 |  |  |  |  |
| 132122020c |  | Zone Test and Check (Reson Ctrl) Labor Revised Per CR12-028 |  | 91d | 2012-10-01 A | 2013-07-15 A | 9-130M | 100% | 2012-10-01 | 2013-02-15 | COMP SCIENT [70.76 h]; SUPPLIES & MATERIALS; ELEC ENG [53.07 h]; ELEC DES [70.76 h]; ELEC TECH [176.89 h] | 26,047.63 | 20,398.77 | 0 | 26047.6281 | HOVATER C | 1 | 1 | 08-009 | 08-016 | U | BILL M | 09-012 | 10-028 | 10-031 | 10-064 | 10-066 |  |  |  |  |  |  | 12-001 | 12-018F | 12-028 |  |  | XX |  |
| 132122020d |  | Zone Test and Check (Reson Ctrl) Procurement Revised Per CR12-028 |  | 99d | 2012-10-01 A | 2013-07-15 A | 9-130M | 100% | 2012-10-01 | 2013-02-28 | PROCUREMENT<$50K 60 | 6,435.03 |  | 0 | 6435.03 | HOVATER C | 1 | 1 | 08-009 | 08-016 | D | BILL M | 09-012 | 10-028 | 10-031 | 10-064 | 10-066 |  | 0 | 6435.03 | 643503 | 100 |  | 12-001 | 12-018F | 12-028 |  |  | XX |  |
| 132122025M |  | Fifth Zone Installed/Tested (RESON CTRL) | milestone | 0d | 2012-10-30 A | 2012-10-30 A | 132122024M FS+20d, 132122020c FS-70d | 100% | 2012-12-04 | 2012-12-04 |  |  |  |  | 0 | HOVATER C | 1 | 1 | 08-009 |  | M | BILL M |  | 10-028 | 10-031 | 10-064 | 10-066 |  |  |  |  |  |  |  | 12-018F | 12-028 | 6 | Install |  |  |
| 132122026M |  | Sixth Zone Installed/Tested (RESON CTRL) | milestone | 0d | 2013-01-28 A | 2013-01-28 A | 132122025M FS+22d | 100% | 2013-02-01 | 2013-02-01 |  |  |  |  | 0 | HOVATER C | 1 | 1 | 08-009 |  | M | BILL M |  | 10-028 | 10-031 | 10-064 | 10-066 |  |  |  |  |  |  |  | 12-018F | 12-028 | 6 | Install | XX |  |
| 132122027M |  | Seventh Zone Installed/Tested (RESON CTRL) | milestone | 0d | 2013-01-28 A | 2013-01-28 A | 132122026M FS+10d | 100% | 2013-02-14 | 2013-02-14 |  |  |  |  | 0 | HOVATER C | 1 | 1 | 08-009 |  | M | BILL M |  | 10-028 | 10-031 | 10-064 | 10-066 |  |  |  |  |  |  |  | 12-018F | 12-028 | 6 | Install | XX |  |
| 132122028M |  | Eighth Zone Installed/Tested (RESON CTRL) | milestone | 0d | 2013-02-20 A | 2013-02-20 A | 132122027M FS+16d | 100% | 2013-03-01 | 2013-03-01 |  |  |  |  | 0 | HOVATER C | 1 | 1 | 08-009 |  | M | BILL M |  | 10-028 | 10-031 | 10-064 | 10-066 |  |  |  |  |  |  |  | 12-018F | 12-028 | 6 | Install | XX |  |
| 132122029M |  | Ninth Zone Installed/Tested (RESON CTRL) | milestone | 0d | 2013-03-07 A | 2013-03-07 A | 132122028M FS+12d | 100% | 2013-04-01 | 2013-04-01 |  |  |  |  | 0 | HOVATER C | 1 | 1 | 08-009 |  | M | BILL M |  | 10-028 | 10-031 | 10-064 | 10-066 |  |  |  |  |  |  |  | 12-018F | 12-028 | 6 | Install | XX |  |
| 132122030M |  | Tenth Zone Installed/Tested (RESON CTRL) | milestone | 0d | 2013-04-19 A | 2013-04-19 A | 132122029M, 132122020d FS-9d | 100% | 2013-06-19 | 2013-06-19 |  |  |  |  | 0 | HOVATER C | 1 | 1 | 08-009 |  | M | BILL M |  | 10-028 | 10-031 | 10-064 | 10-066 |  |  |  |  |  |  |  | 12-018F | 12-028 | 6 | Install | XX |  |
| 132122035 |  | Re-Baseline Actuals Adjustment |  | 1d | 2013-08-30 A | 2013-08-30 A |  | 100% | 2013-09-03 | 2013-09-03 | PROCUREMENT>$50K 69 NO ESCALATION | -93,721.4 |  |  |  |  |  |  |  |  |  |  |  |  |  |  |  |  |  |  |  | 100 |  |  |  |  |  |  |  | ADJ |

Notes:
- 132122001: Steps: Buy Stepper Motor Parts (done); Buy PZT Parts (done); Buy Interlock Parts (done); Buy Heater Parts (done)

| ID | WBS | Activity | Type | Duration | Start | Finish | Predecessors | Complete | Planned start | Planned finish | Resources | Cost | Actual cost | Calculated Remaining Total Cost | MONTHLY EV COST | RESP - Responsibility | STRT%COMP for CM EVM | FNSH%COMP for CM EVM | CR 08-009 | CR 08-016 | EVMS Reporting Codes | CAM RESPONSIBLE | CR 09-012 | CR 10-028 | CR 10-031 | CR 10-064 | CR 10-066 | CR 11-001 | CR 12-018 | CR 12-028 | CR 13-009 | Remaining Material Cost Based on % Compl | Claimed Material Cost Based on % Complet | Initial Claimed Material Calc | Claimed Material Divider | Activities with Steps | Installation | CR 12-001 | Milestone Level | ReBaseline Actuals Adjustment | CR 08-052 |
| --- | --- | --- | --- | --- | --- | --- | --- | --- | --- | --- | --- | --- | --- | --- | --- | --- | --- | --- | --- | --- | --- | --- | --- | --- | --- | --- | --- | --- | --- | --- | --- | --- | --- | --- | --- | --- | --- | --- | --- | --- | --- |
|  | 3 | **1.3.2.1.2.3 PACKAGING/INTERFACE (Racks, Crates)** |  |  | 2009-10-30 | 2013-08-30 |  |  |  |  |  |  |  |  |  |  |  |  |  |  |  |  |  |  |  |  |  |  |  |  |  |  |  |  |  |  |  |  |  |  |  |
| 132123000 |  | Bid & Award Racks & Cabling FY10 |  | 141d | 2009-10-30 A | 2010-05-31 A | 1212123170 | 100% | 2009-10-30 | 2010-05-28 | ELEC ENG [14 h]; ELEC DES [84 h]; ELEC TECH [14 h]; OFFICE [56 h] | 6,994.4 | 6,994.4 | 0 | 6994.4 | HOVATER C | 1 | 1 | 08-009 | 08-016 | H | BILL M | 09-012 | 10-028 | 10-031 | 10-064 | 10-066 | 11-001 | 12-018F | 12-028F | 13-009F |  |  |  |  |  |  |  |  |  |  |
| 132123000a |  | Bid & Award Racks & Cabling FY11 |  | 141d | 2009-10-30 A | 2010-05-31 A | 1212123170 | 100% | 2009-10-30 | 2010-05-28 | ELEC DES [156 h]; ELEC TECH [26 h]; OFFICE [104 h]; ELEC ENG [26 h] | 12,989.6 | 12,989.6 | 0 | 13403.78 | HOVATER C | 1 | 1 | 08-009 | 08-016 | H | BILL M | 09-012 | 10-028 | 10-031 | 10-064 | 10-066 | 11-001 | 12-018F | 12-028F | 13-009F |  |  |  |  |  |  |  |  |  |  |
| 132123001 |  | Vend Fab Racks & Cabling |  | 260d | 2009-11-30 A | 2010-12-15 A | 9-110M FS-500d, 132123000 FS-200d, 132123000a FS-200d | 100% |  |  | PROCUREMENT<$50K 60 | 204,090.58 |  | 0 | 204090.58 | HOVATER C | 1 | 1 | 08-009 |  | D | BILL M |  | 10-028 | 10-031 | 10-064 | 10-066 |  | 12-018F | 12-028F | 13-009F | 0 | 204090.58 | 20409058 | 100 |  |  |  |  |  |  |
| 132123005 |  | Production Pwr Supply Delivered & Tested |  | 29d | 2010-05-20 A | 2010-06-30 A | 1212123055M, 9-100M FS+155d | 100% |  |  | OFFICE [80 h]; PROCUREMENT<$50K 60; ELEC ENG [40 h]; ELEC DES [160 h]; ELEC TECH [160 h] | 51,981.56 | 19,018 | 0 | 51981.560507 | HOVATER C | 1 | 1 | 08-009 |  | D | BILL M |  | 10-028 | 10-031 | 10-064 | 10-066 |  | 12-018F | 12-028F | 13-009F | 0 | 32963.560507 | 3296356.0507 | 100 |  |  |  |  |  |  |
| 132123010 |  | Fab Chassis & Cable Harnesses Labor FY10 |  | 275d | 2010-05-24 A | 2011-06-30 A | 132123005 FS-85d | 100% |  |  | ELEC DES [144.44 h]; ELEC TECH [609.88 h]; OFFICE [32.1 h]; SUPPLIES & MATERIALS | 34,665.33 | 33,695.41 | 0 | 33962.2806 | HOVATER C | 1 | 1 | 08-009 |  | U | BILL M |  | 10-028 | 10-031 | 10-064 | 10-066 | 11-001 | 12-018F | 12-028F | 13-009F |  |  |  |  |  |  |  |  |  |  |
| 132123010a |  | Fab Chassis & Cable Harnesses Labor FY11 |  | 275d | 2010-05-24 A | 2011-06-30 A | 132123010 FS-162d | 100% |  |  | SUPPLIES & MATERIALS; ELEC DES [215.56 h]; ELEC TECH [910.12 h]; OFFICE [47.9 h] | 51,777.58 | 50,284 | 0 | 52296.4674 | HOVATER C | 1 | 1 | 08-009 |  | U | BILL M |  | 10-028 | 10-031 | 10-064 | 10-066 | 11-001 | 12-018F | 12-028F | 13-009F |  |  |  |  |  |  |  |  |  |  |
| 132123010b |  | Fab Chassis & Cable Harnesses Procurement |  | 275d | 2010-05-24 A | 2011-06-30 A | 132123005 FS-85d | 100% |  |  | PROCUREMENT<$50K 60 NO ESCALATION FY11 | 32,963.56 |  | 0 | 32963.56 | HOVATER C | 1 | 1 | 08-009 |  | U | BILL M |  | 10-028 | 10-031 | 10-064 | 10-066 | 11-001 | 12-018F | 12-028F | 13-009F | 0 | 32963.560507 | 3296356.0507 | 100 |  |  |  |  |  |  |
| 132123012 |  | Install Rack Supports & Conduit |  | 42d | 2010-07-01 A | 2010-08-30 A | 9-100M FS+185d | 100% |  |  | MECH TECH [640 h]; SUPPLIES & MATERIALS | 36,713.6 | 26,713.6 | 0 | 36713.6 | HOVATER C | 1 | 1 | 08-009 |  | S | BILL M |  | 10-028 | 10-031 |  | 10-066 |  | 12-018F | 12-028F | 13-009F |  |  |  |  | ST |  |  |  |  |  |
| 132123015 |  | Install Chassis, Racks & Cabling Labor FY11 |  | 327.1d | 2010-11-15 A | 2012-03-19 A | 132123001 FS-117d, 132123010b FS-95d, 132123012, 132123010a FS-95d, 1321122042a FS-85d, 1321122042 FS-85d | 100% |  |  | SKLLD TRADE [159.25 h]; SUPPLIES & MATERIALS; ELEC DES [318.49 h]; ELEC TECH [1154.53 h]; OFFICE [79.62 h]; ELEC ENG [836.04 h] | 134,378.74 | 131,013.14 | 0 | 132990.7492 | HOVATER C | 1 | 1 | 08-009 | 08-016 | U | BILL M | 09-012 | 10-028 | 10-031 | 10-064 | 10-066 |  | 12-018F | 12-028F | 13-009F |  |  |  |  |  | Install | 12-001 |  |  |  |
| 132123015a |  | Install Chassis, Racks & Cabling Labor FY12 |  | 328d | 2010-11-15 A | 2012-03-19 A | 132123015 FS-50d | 100% |  |  | SUPPLIES & MATERIALS; ELEC ENG [3.96 h]; SKLLD TRADE [0.75 h]; ELEC DES [1.51 h]; ELEC TECH [5.47 h]; OFFICE [0.38 h] | 637.16 | 620.1 | 0 | 650.0753 | HOVATER C | 1 | 1 | 08-009 | 08-016 | U | BILL M | 09-012 | 10-028 | 10-031 | 10-064 | 10-066 |  | 12-018F | 12-028F | 13-009F |  |  |  |  |  |  | 12-001 |  |  |  |
| 132123015b |  | Install Chassis, Racks & Cabling Labor Procurement |  | 328d | 2010-11-15 A | 2012-03-19 A | 1321122042a FS-85d, 1321122042 FS-85d, 132123010a FS-95d, 132123010b FS-95d, 132123012, 132123001 FS-117d | 100% |  |  | PROCUREMENT<$50K 60 NO ESCALATION FY12 | 11,701.2 |  | 0 | 11701.2 | HOVATER C | 1 | 1 | 08-009 | 08-016 | U | BILL M | 09-012 | 10-028 | 10-031 | 10-064 | 10-066 |  | 12-018F | 12-028F | 13-009F | 0 | 11701.2 | 1170120 | 100 |  |  | 12-001 |  |  |  |
| 132123020M |  | 5 Racks Installed (PACKAGING) | milestone | 0d | 2011-06-30 A | 2011-06-30 A | 132123015 FS-85d, 132123015a FS-85d, 132123015b FS-85d | 100% | 2011-07-01 | 2011-07-01 |  |  |  |  | 0 | HOVATER C | 1 | 1 | 08-009 |  | M | BILL M |  | 10-028 | 10-031 | 10-064 | 10-066 |  | 12-018F | 12-028F | 13-009F |  |  |  |  |  | Install |  | 6 |  |  |
| 132123025M |  | All Racks Installed (PACKAGING) | milestone | 0d | 2011-09-26 A | 2011-09-26 A | 132123015b FS+78d, 132123015 FS+78d, 132123015a FS+78d | 100% | 2012-03-02 | 2012-03-02 |  |  |  |  | 0 | HOVATER C | 1 | 1 | 08-009 |  | M | BILL M |  | 10-028 |  | 10-064 | 10-066 |  |  | 12-028F | 13-009F |  |  |  |  |  | Install |  | 6 |  |  |
| 132123030 |  | Re-Baseline Actuals Adjustment |  | 1d | 2013-08-30 A | 2013-08-30 A |  | 100% | 2013-09-03 | 2013-09-03 | PROCUREMENT>$50K 69 NO ESCALATION | -28,472.92 |  |  |  |  |  |  |  |  |  |  |  |  |  |  |  |  |  |  |  |  |  |  | 100 |  |  |  |  | ADJ |  |
|  | 4 | **1.3.2.1.2.4 CPU & SOFTWARE** |  |  | 2010-02-08 | 2013-08-30 |  |  |  |  |  |  |  |  |  |  |  |  |  |  |  |  |  |  |  |  |  |  |  |  |  |  |  |  |  |  |  |  |  |  |  |
| 132124000 |  | Bid & Award PC104 & Test (CPU) |  | 101d | 2010-02-08 A | 2010-06-30 A | 9-100M FS+100d | 100% |  |  | ELEC DES [80 h]; COMP SCIENT [80 h]; SUPPLIES & MATERIALS; ELEC TECH [80 h] | 14,458.13 | 12,040.8 | 0 | 14458.12894 | HOVATER C | 1 | 1 | 08-009 |  | H | BILL M | 09-012 | 10-028 | 10-031 | 10-064 | 10-066 |  |  |  |  |  |  |  |  |  |  |  |  |  |  |
| 132124001 |  | Vend Fab PC104 & Test (CPU) |  | 64d | 2010-04-26 A | 2010-07-26 A | 9-100M FS+60d, 132124000 FS-60d | 100% |  |  | PROCUREMENT>$50K 69 NO ESCALATION FY11; PROCUREMENT<$50K 60 NO ESCALATION FY11 | 67,575.29 |  | 0 | 67575.292332 | HOVATER C | 1 | 1 | 08-009 | 08-016 | D | BILL M | 09-012 | 10-028 | 10-031 | 10-064 | 10-066 |  |  |  |  | 0 | 67575.292332 | 6757529.2332 | 100 |  |  |  |  |  |  |
| 132124005 |  | EPICS Interface (CPU) |  | 400d | 2010-08-16 A | 2012-03-29 A | 132124001 | 100% |  |  | SUPPLIES & MATERIALS; ELEC DES [80 h]; PROCUREMENT<$50K 60; COMP SCIENT [80 h] | 13,703.07 | 9,065.67 | 0 | 13640.6 | HOVATER C | 1 | 1 | 08-009 | 08-016 | H | BILL M | 09-012 | 10-028 | 10-031 | 10-064 | 10-066 |  |  |  |  | 0 | 1133.84 | 113384 | 100 |  |  |  |  |  |  |
| 132124010 |  | Test Software (CPU) |  | 162d | 2010-09-01 A | 2011-04-29 A | 132124005 FS-200d, 132124001 FS+20d | 100% |  |  | COMP SCIENT [80 h]; ELEC DES [80 h] | 8,967.11 | 8,967.11 | 0 | 9003.2 | HOVATER C | 1 | 1 | 08-009 |  | H | BILL M |  | 10-028 | 10-031 | 10-064 | 10-066 |  |  |  |  |  |  |  |  |  |  |  |  |  | 08-052 |
| 132124015 |  | Re-Baseline Actuals Adjustment |  | 1d | 2013-08-30 A | 2013-08-30 A |  | 100% | 2013-09-03 | 2013-09-03 | PROCUREMENT>$50K 69 NO ESCALATION | -59,773.37 |  |  |  |  |  |  |  |  |  |  |  |  |  |  |  |  |  |  |  |  |  |  | 100 |  |  |  |  | ADJ |  |
|  | 5 | **1.3.2.1.2.5 TEST STAND** |  |  | 2010-01-29 | 2013-08-30 |  |  |  |  |  |  |  |  |  |  |  |  |  |  |  |  |  |  |  |  |  |  |  |  |  |  |  |  |  |  |  |  |  |  |  |
| 132125000 |  | Bid & Award Test Equipment (Test STAND) |  | 149d | 2010-01-29 A | 2010-08-30 A | 9-100M FS+24d | 100% |  |  | ELEC ENG [80 h]; ELEC DES [80 h] | 9,096.8 | 9,096.8 | 0 | 9096.8 | HOVATER C | 1 | 1 | 08-009 |  | H | BILL M | 09-012 | 10-028 | 10-031 | 10-064 | 10-066 |  |  | 12-028F |  |  |  |  |  |  |  |  |  |  |  |
| 132125010 |  | Automation Software FY10 |  | 328d | 2010-01-29 A | 2011-05-23 A | 132125005 FS-200d | 100% |  |  | ELEC DES [98.35 h]; COMP SCIENT [245.87 h]; ELEC ENG [49.17 h] | 23,427.32 | 23,427.32 | 0 | 23074.7293 | HOVATER C | 1 | 1 | 08-009 |  | H | BILL M |  | 10-028 | 10-031 | 10-064 | 10-066 | 11-001 |  | 12-028F |  |  |  |  |  |  |  |  |  |  |  |
| 132125010a |  | Automation Software FY11 |  | 327.42d | 2010-01-29 A | 2011-05-23 A | 132125005 FS-200d | 100% |  |  | ELEC ENG [30.83 h]; ELEC DES [61.65 h]; COMP SCIENT [154.13 h] | 14,685.88 | 14,703.86 | 0 | 14927.0496 | HOVATER C | 1 | 1 | 08-009 |  | H | BILL M |  | 10-028 | 10-031 | 10-064 | 10-066 | 11-001 |  | 12-028F |  |  |  |  |  |  |  |  |  |  |  |
| 132125001 |  | Vend Fab Test Equipment (Test STAND) |  | 148d | 2010-02-15 A | 2010-09-14 A | 132125000 FS-41d, 9-100M | 100% | 2010-02-16 | 2010-09-14 | PROCUREMENT<$50K 60 | 113,394.64 |  | 0 | 113394.64484 | HOVATER C | 1 | 1 | 08-009 |  | D | BILL M |  | 10-028 | 10-031 | 10-064 | 10-066 |  |  | 12-028F |  | 0 | 113394.64484 | 11339464.484 | 100 |  |  |  |  |  |  |
| 132125005 |  | Assemble Test Stand (Test STAND) |  | 143d | 2010-05-24 A | 2010-12-15 A | 132125001 FS-55d | 100% |  |  | SUPPLIES & MATERIALS; ELEC DES [160 h]; ELEC TECH [480 h]; PROCUREMENT<$50K 60; ELEC ENG [80 h] | 73,756.77 | 33,167.63 | 0 | 73377.136403 | HOVATER C | 1 | 1 | 08-009 |  | U | BILL M |  | 10-028 | 10-031 | 10-064 | 10-066 |  |  | 12-028F |  | 0 | 38149.827993 | 3814982.7993 | 100 |  |  |  |  |  |  |
| 132125015 |  | Program Cavity Simulator (Test STAND) FY10 |  | 183d | 2010-05-24 A | 2011-02-21 A | 132125001 FS-55d | 100% | 2010-05-24 | 2011-02-18 | ELEC ENG [464.76 h]; ELEC DES [232.38 h] | 42,493.16 | 42,493.16 | 0 | 41823.7524 | HOVATER C | 1 | 1 | 08-009 |  | H | BILL M |  | 10-028 | 10-031 | 10-064 | 10-066 | 11-001 |  | 12-028F |  |  |  |  |  |  |  |  |  |  |  |
| 132125015a |  | Program Cavity Simulator (Test STAND) FY11 |  | 183d | 2010-05-24 A | 2011-02-21 A | 132125001 FS-55d | 100% | 2010-05-24 | 2011-02-18 | ELEC DES [7.62 h]; ELEC ENG [15.24 h] | 1,393.4 | 1,393.4 | 0 | 1415.1102 | HOVATER C | 1 | 1 | 08-009 |  | H | BILL M |  | 10-028 | 10-031 | 10-064 | 10-066 | 11-001 |  | 12-028F |  |  |  |  |  |  |  |  |  |  |  |
| 132125020 |  | Test Automation (Test STAND) |  | 175d | 2010-12-15 A | 2011-08-30 A | 132125015 FS-75d, 132125015a FS-65d, 132125005, 132125010 FS-55d, 132125010a FS-40d | 100% |  |  | SUPPLIES & MATERIALS; ELEC ENG [160 h]; ELEC DES [160 h]; ELEC TECH [400 h]; COMP SCIENT [160 h]; PROCUREMENT<$50K 60 | 62,439.15 | 46,055.2 | 0 | 62439.15 | HOVATER C | 1 | 1 | 08-009 |  | U | BILL M |  | 10-028 | 10-031 | 10-064 | 10-066 |  |  | 12-028F |  | 0 | 11701.2 | 1170120 | 100 |  |  |  |  |  |  |
| 132125025 |  | Re-Baseline Actuals Adjustment |  | 1d | 2013-08-30 A | 2013-08-30 A |  | 100% | 2013-09-03 | 2013-09-03 | PROCUREMENT>$50K 69 NO ESCALATION | -116,587.08 |  |  |  |  |  |  |  |  |  |  |  |  |  |  |  |  |  |  |  |  |  |  | 100 |  |  |  |  | ADJ |  |

Notes:
- 132123012: Steps: Rack Supports NL (done); Conduit NL (done); Rack Supports SL (done); Conduit SL (done)

| ID | WBS | Activity | Type | Duration | Start | Finish | Predecessors | Complete | Planned start | Planned finish | Total float | Free float | Calendar | Resources | Cost | Actual cost | Calculated Remaining Total Cost | MONTHLY EV COST | RESP - Responsibility | STRT%COMP for CM EVM | FNSH%COMP for CM EVM | CR 08-009 | EVMS Reporting Codes | CAM RESPONSIBLE | CR 09-012 | CR 10-028 | CR 10-031 | CR 10-064 | CR 10-066 | Remaining Material Cost Based on % Compl | Claimed Material Cost Based on % Complet | Initial Claimed Material Calc | Claimed Material Divider | Activities with Steps | Milestone Level | Installation | CR 12-001 | CR 12-028 | MARCH!!! | ReBaseline Actuals Adjustment | CR 12-018 | Original Activity ID Rebaseline | CR 13-015 | Post Rebaseline |
| --- | --- | --- | --- | --- | --- | --- | --- | --- | --- | --- | --- | --- | --- | --- | --- | --- | --- | --- | --- | --- | --- | --- | --- | --- | --- | --- | --- | --- | --- | --- | --- | --- | --- | --- | --- | --- | --- | --- | --- | --- | --- | --- | --- | --- |
|  | 6 | **1.3.2.1.2.6 MASTER OSCILLATOR** |  |  |  |  |  |  |  |  |  |  |  |  |  |  |  |  |  |  |  |  |  |  |  |  |  |  |  |  |  |  |  |  |  |  |  |  |  |  |  |  |  |  |
|  | 7 | **1.3.2.1.2.7 HPA CONTROLS** |  |  | 2009-08-24 | 2013-08-30 |  |  |  |  |  |  |  |  |  |  |  |  |  |  |  |  |  |  |  |  |  |  |  |  |  |  |  |  |  |  |  |  |  |  |  |  |  |  |
| 132127000 |  | Bid & Award HPA Board (HPA CNTLS) |  | 40d | 2009-08-24 A | 2009-10-19 A | 1212127065M FS-500d, 1212127170 FS-500d, 9-110M FS-500d | 100% |  |  |  |  |  | OFFICE [40 h]; ELEC ENG [40 h]; ELEC DES [80 h] | 7,362.07 | 7,362.07 | 0 | 7758 | HOVATER C | 1 | 1 | 08-009 | H | BILL M | 09-012 | 10-028 | 10-031 | 10-064 | 10-066 |  |  |  |  |  |  |  |  |  |  |  |  |  |  |  |
| 132127001 |  | Vend Fab HPA Board (HPA CNTLS) |  | 121d | 2009-10-26 A | 2010-04-26 A | 132127000 FS-500d | 100% |  |  |  |  |  | PROCUREMENT<$50K 60 | 40,954.17 |  | 0 | 40954.17 | HOVATER C | 1 | 1 | 08-009 | S | BILL M |  | 10-028 | 10-031 | 10-064 | 10-066 | 0 | 40954.17 | 4095417 | 100 | ST |  |  |  |  |  |  |  |  |  |  |
| 132127005 |  | First Article Test (HPA CNTLS) |  | 15d | 2009-11-30 A | 2009-12-21 A | 9-110M FS-500d | 100% | 2009-11-30 | 2009-12-18 |  |  |  | ELEC DES [80 h]; ELEC TECH [160 h]; ELEC ENG [80 h] | 15,728.8 | 15,728.8 | 0 | 16229.6 | HOVATER C | 1 | 1 | 08-009 | H | BILL M |  | 10-028 | 10-031 | 10-064 | 10-066 |  |  |  |  |  |  |  |  |  |  |  |  |  |  |  |
| 132127015 |  | Chassis Fab & Test (HPA CNTLS) |  | 208d | 2010-01-29 A | 2010-11-22 A | 132127005 FS-500d, 132127010M FS-500d | 100% |  |  |  |  |  | ELEC TECH [800 h]; COMP SCIENT [80 h]; OFFICE [80 h]; PROCUREMENT<$50K 60; SUPPLIES & MATERIALS; ELEC DES [520 h]; ELEC ENG [80 h] | 92,837.17 | 70,602.63 | 0 | 94675.74 | HOVATER C | 1 | 1 | 08-009 | U | BILL M |  | 10-028 | 10-031 | 10-064 | 10-066 | 0 | 17551.79 | 1755179 | 100 |  |  |  |  |  |  |  |  |  |  |  |
| 132127010M |  | Final Board Delivered (HPA CNTLS) | milestone | 0d | 2010-04-26 A | 2010-04-26 A | 132127005, 132127001 | 100% | 2011-05-03 | 2011-05-03 |  |  |  |  |  |  |  | 0 | HOVATER C | 1 | 1 | 08-009 | M | BILL M |  | 10-028 | 10-031 | 10-064 | 10-066 |  |  |  |  |  | 6 |  |  |  |  |  |  |  |  |  |
| 132127020M |  | Final Bench Test (HPA CNTLS) | milestone | 0d | 2010-11-22 A | 2010-11-22 A | 132127015 FS-140d, 132127010M FS-33d | 100% | 2010-12-01 | 2010-12-01 |  |  |  |  |  |  |  | 0 | HOVATER C | 1 | 1 | 08-009 | M | BILL M |  | 10-028 | 10-031 | 10-064 | 10-066 |  |  |  |  |  | 6 |  |  |  |  |  |  |  |  |  |
| 132127025 |  | Installtn (HPA CNTLS) Labor FY11 Frozen per CR 12-028 |  | 232.04d | 2011-04-02 A | 2012-03-12 A | 132127020M FS+60d | 100% | 2011-04-04 | 2012-03-12 |  |  |  | OFFICE [25.91 h]; ELEC ENG [51.82 h]; ELEC TECH [285.02 h]; ELEC DES [103.64 h]; SUPPLIES & MATERIALS | 23,471.84 | 21,833.99 | 0 | 23161.7247 | HOVATER C | 1 | 1 | 08-009 | U | BILL M |  | 10-028 | 10-031 | 10-064 | 10-066 |  |  |  |  |  |  | Install | 12-001 |  |  |  |  |  |  |  |
| 132127025a |  | Installtn (HPA CNTLS) Labor FY12 Frozen per CR 12-028 |  | 233d | 2011-04-02 A | 2012-03-12 A | 132127025 FS-90d | 100% | 2011-04-04 | 2012-03-12 |  |  |  | SUPPLIES & MATERIALS; OFFICE [14.09 h]; ELEC TECH [154.98 h]; ELEC DES [56.36 h]; ELEC ENG [28.18 h] | 12,792.61 | 11,873.61 | 0 | 12995.6613 | HOVATER C | 1 | 1 | 08-009 | U | BILL M |  | 10-028 | 10-031 | 10-064 | 10-066 |  |  |  |  |  |  |  | 12-001 |  |  |  |  |  |  |  |
| 132127025b |  | Installtn (HPA CNTLS) Procurement Frozen per CR 12-028 |  | 233d | 2011-04-02 A | 2012-03-12 A | 132127020M FS+60d | 100% | 2011-04-04 | 2012-03-12 |  |  |  | PROCUREMENT<$50K 60 NO ESCALATION FY12 | 13,526.66 |  | 0 | 13526.66 | HOVATER C | 1 | 1 | 08-009 | U | BILL M |  | 10-028 | 10-031 | 10-064 | 10-066 | 0 | 13526.66 | 1352666 | 100 |  |  |  | 12-001 |  |  |  |  |  |  |  |
| 132127040 |  | Reverse Entry per CR12-028 |  | 8d | 2012-03-01 A | 2012-03-12 A | 9-120M FS+100d | 100% |  |  |  |  |  | SUPPLIES & MATERIALS; OFFICE [-20 h]; ELEC TECH [-220 h]; ELEC DES [-80 h]; ELEC ENG [-40 h]; PROCUREMENT<$50K 60 | -25,184.56 | -17,142.8 |  |  | HOVATER C | 1 | 1 | 08-009 | Z | BILL M |  | 10-028 | 10-031 | 10-064 | 10-066 |  |  |  | 100 |  |  |  | 12-001 | 12-028 |  |  |  |  |  |  |
| 132127030 |  | Installtn (HPA CNTLS) Labor Revised per CR12-028 |  | 91d | 2012-10-01 A | 2013-06-17 A | 9-130M | 100% | 2012-10-01 | 2013-02-15 |  |  |  | SUPPLIES & MATERIALS; OFFICE [20 h]; ELEC TECH [220 h]; ELEC DES [80 h]; ELEC ENG [40 h] | 19,009.21 | 17,690 | 0 | 19009.21 | HOVATER C | 1 | 1 | 08-009 | U | BILL M |  | 10-028 | 10-031 | 10-064 | 10-066 |  |  |  |  |  |  |  | 12-001 | 12-028 | XX |  |  |  |  |  |
| 132127035 |  | Installtn (HPA CNTLS) Procurement Revised per CR12-028 |  | 99d | 2012-10-01 A | 2013-06-17 A | 9-130M | 100% | 2012-10-01 | 2013-02-28 |  |  |  | PROCUREMENT<$50K 60 | 6,979.08 |  | 0 | 6979.08 | HOVATER C | 1 | 1 | 08-009 | D | BILL M |  | 10-028 | 10-031 | 10-064 | 10-066 | 0 | 6979.08 | 697908 | 100 |  |  |  | 12-001 | 12-028 | XX |  |  |  |  |  |
| 132127045 |  | Re-Baseline Actuals Adjustment |  | 1d | 2013-08-30 A | 2013-08-30 A |  | 100% | 2013-09-03 | 2013-09-03 |  |  |  | PROCUREMENT>$50K 69 NO ESCALATION | -26,038.81 |  |  |  |  |  |  |  |  |  |  |  |  |  |  |  |  |  | 100 |  |  |  |  |  |  | ADJ |  |  |  |  |
|  | 3 | **1.3.2.1.3 INSTALLATION & SYSTEM COMMISSIONING (Test Equipment, System Integration Labor)** |  |  | 2010-10-01 | 2013-12-13 |  |  |  |  |  |  |  |  |  |  |  |  |  |  |  |  |  |  |  |  |  |  |  |  |  |  |  |  |  |  |  |  |  |  |  |  |  |  |
| 13213000 |  | BId & Award Test Equipment (Install & SYS COMMIS) |  | 116d | 2010-10-01 A | 2011-03-25 A | 132121045a FS-40d, 132121045b FS-40d, 132121045 FS-40d, 9-110M | 100% |  |  |  |  |  | SUPPLIES & MATERIALS; ELEC ENG [80 h]; ELEC DES [80 h] | 12,889.96 | 9,386.4 | 0 | 12889.96 | HOVATER C | 1 | 1 | 08-009 | H | BILL M | 09-012 |  | 10-031 | 10-064 | 10-066 |  |  |  |  |  |  | Install |  |  |  |  |  |  |  |  |
| 13213001 |  | Vend Fab Test Equipment (Install & SYS COMMIS) |  | 103d | 2011-03-01 A | 2011-07-25 A | 9-110M FS+60d, 13213000 | 100% |  |  |  |  |  | PROCUREMENT<$50K 60 | 81,636.23 |  | 0 | 81636.23 | HOVATER C | 1 | 1 | 08-009 | D | BILL M |  |  | 10-031 | 10-064 | 10-066 | 0 | 81636.23 | 8163623 | 100 |  |  | Install |  |  |  |  |  |  |  |  |
| 13213005 |  | Fab & Program RF Test Stand (Install & SYS COMMIS) |  | 115d | 2011-04-04 A | 2011-09-14 A | 13213001 FS-35d, 1212125025M | 100% |  |  |  |  |  | SUPPLIES & MATERIALS; ELEC ENG [320 h]; ELEC DES [200 h]; ELEC TECH [200 h]; COMP SCIENT [400 h] | 68,099.35 | 65,661.6 | 0 | 68099.35 | HOVATER C | 1 | 1 | 08-009 | U | BILL M | 09-012 |  | 10-031 | 10-064 | 10-066 |  |  |  |  |  |  | Install |  |  |  |  |  |  |  |  |
| 13213010 |  | RF Sys Tests #1 (Install & SYS COMMIS) |  | 24d | 2011-07-11 A | 2011-08-11 A | 132121061M, 132122015a, 132122015b, 132122010a, 132122015, 132122010b, 132127020M, 131501000 FS-40d, 132122010c, 132124010, 132112081M FS-30d, 13213005 FS-40d | 100% |  |  |  |  |  | ELEC DES [56 h]; ELEC TECH [100 h]; COMP SCIENT [16 h]; OFFICE [8 h]; SUPPLIES & MATERIALS; ELEC ENG [16 h] | 9,594.86 | 9,351.08 | 0 | 9594.86 | HOVATER C | 1 | 1 | 08-009 | H | BILL M |  | 10-028 | 10-031 | 10-064 | 10-066 |  |  |  |  |  |  | Install |  |  |  |  |  |  |  |  |
| 13213010a |  | RF Sys Tests #2 (Install & SYS COMMIS) |  | 39d | 2011-07-18 A | 2011-09-10 A | 132121062M, 131502000 FS-60d, 132112082M FS-40d | 100% | 2011-07-18 | 2011-09-09 |  |  |  | COMP SCIENT [16 h]; OFFICE [8 h]; SUPPLIES & MATERIALS; ELEC DES [56 h]; ELEC ENG [16 h]; ELEC TECH [100 h] | 9,594.86 | 9,351.08 | 0 | 9594.86 | HOVATER C | 1 | 1 | 08-009 | H | BILL M |  | 10-028 | 10-031 |  | 10-066 |  |  |  |  |  |  |  |  |  |  |  |  |  |  |  |
| 13213015 |  | RF Cavity Tests Cryomodule #1 (Install & SYS COMMIS) |  | 35d | 2011-08-01 A | 2011-09-19 A | 13213010, 131501005 FS-40d | 100% |  |  |  |  |  | ELEC ENG [16 h]; ELEC DES [64 h]; ELEC TECH [60 h]; SCIENTIST [16 h]; OFFICE [8 h]; SUPPLIES & MATERIALS | 8,351.96 | 8,109.32 | 0 | 8351.96 | HOVATER C | 1 | 1 | 08-009 | H | BILL M |  |  |  | 10-064 | 10-066 |  |  |  |  |  |  | Install |  |  |  |  |  |  |  |  |
| 13213010b |  | RF Sys Tests #3 (Install & SYS COMMIS) |  | 92d | 2011-09-26 A | 2012-02-13 A | 132112083M FS-5d, 132121063M, 131504000 | 100% |  |  |  |  |  | ELEC TECH [100 h]; COMP SCIENT [16 h]; OFFICE [8 h]; SUPPLIES & MATERIALS; ELEC DES [56 h]; ELEC ENG [16 h] | 9,884.21 | 9,632.65 | 0 | 9900.4 | HOVATER C | 1 | 1 | 08-009 | H | BILL M |  | 10-028 | 10-031 |  | 10-066 |  |  |  |  |  |  |  |  | 12-028 |  |  | 12-018 |  |  |  |
| 13213015a |  | RF Cavity Tests Cryomodule #2 (Install & SYS COMMIS) FY11 |  | 11d | 2011-10-03 A | 2011-10-17 A | 13213010a, 131502005a FS-18d | 100% |  |  |  |  |  | SCIENTIST [13.33 h]; OFFICE [6.67 h]; SUPPLIES & MATERIALS; ELEC ENG [13.33 h]; ELEC DES [53.33 h]; ELEC TECH [50 h] | 7,174.62 | 6,972.42 | 0 | 6959.4397 | HOVATER C | 1 | 1 | 08-009 | H | BILL M |  |  |  |  | 10-066 |  |  |  |  |  |  |  | 12-001 |  |  |  |  |  |  |  |
| 13213015ab |  | RF Cavity Tests Cryomodule #2 (Install & SYS COMMIS) FY12 |  | 11d | 2011-10-03 A | 2011-10-17 A | 13213015a | 100% |  |  |  |  |  | SUPPLIES & MATERIALS; ELEC ENG [2.67 h]; ELEC DES [10.67 h]; ELEC TECH [10 h]; SCIENTIST [2.67 h]; OFFICE [1.33 h] | 1,436.87 | 1,395.14 | 0 | 1436.8671 | HOVATER C | 1 | 1 | 08-009 | H | BILL M |  |  |  |  | 10-066 |  |  |  |  |  |  |  | 12-001 |  |  |  |  |  |  |  |
| 13213010c |  | RF Sys Tests #4 (Install & SYS COMMIS) |  | 135d | 2011-11-01 A | 2012-05-21 A | 132121064M FS-60d, 131505000 FS-70d, 132112084M FS-20d | 100% |  |  |  |  |  | ELEC TECH [100 h]; COMP SCIENT [16 h]; OFFICE [8 h]; SUPPLIES & MATERIALS; ELEC DES [56 h]; ELEC ENG [16 h] | 9,900.4 | 9,648.84 | 0 | 9900.4 | HOVATER C | 1 | 1 | 08-009 | H | BILL M |  | 10-028 | 10-031 |  | 10-066 |  |  |  |  |  |  |  |  | 12-028 |  |  | 12-018 |  |  |  |
| 13213015c |  | RF Cavity Tests Cryomodule #4 (Install & SYS COMMIS) |  | 17d | 2012-06-25 A | 2012-07-17 A | 131504005 FS-30d, 13213010c | 100% |  |  |  |  |  | SCIENTIST [16 h]; OFFICE [8 h]; SUPPLIES & MATERIALS; ELEC ENG [16 h]; ELEC DES [64 h]; ELEC TECH [60 h] | 8,617.94 | 8,367.56 | 0 | 8617.94 | HOVATER C | 1 | 1 | 08-009 | H | BILL M |  |  |  |  | 10-066 |  |  |  |  |  |  |  |  | 12-028 |  |  | 12-018 |  |  |  |
| 13213015d |  | RF Cavity Tests Cryomodule #5 (Install & SYS COMMIS) |  | 7d | 2012-07-16 A | 2012-07-24 A | 131505005 FS-8d, 13213010b | 100% |  |  |  |  |  | SCIENTIST [16 h]; OFFICE [8 h]; SUPPLIES & MATERIALS; ELEC ENG [16 h]; ELEC DES [64 h]; ELEC TECH [60 h] | 8,617.94 | 8,367.56 | 0 | 8617.94 | HOVATER C | 1 | 1 | 08-009 | H | BILL M |  |  |  |  | 10-066 |  |  |  |  |  |  |  |  | 12-028 |  |  | 12-018 |  |  |  |
| 13213025 |  | Re-Baseline Actuals Adjustment |  | 1d | 2013-08-30 A | 2013-08-30 A |  | 100% | 2013-09-03 | 2013-09-03 |  |  |  | PROCUREMENT>$50K 69 NO ESCALATION | -13,235.28 |  |  |  |  |  |  |  |  |  |  |  |  |  |  |  |  |  | 100 |  |  |  |  |  |  | ADJ |  |  |  |  |
| 13213020M |  | Comp Cavity Tests (INSTALL & SYS COMMIS) | milestone | 0d | 2013-08-30 A | 2013-08-30 A | 13213015c, 181321055, 132122005, 181321030, 181321035, 13213015d, 13213015, 181321040, 181315025, 181321045, 13213015ab, 181321050, 132113125 | 100% | 2013-09-30 | 2013-09-30 |  |  |  |  |  |  |  | 0 | HOVATER C | 1 | 1 | 08-009 | M | BILL M |  |  |  |  | 10-066 |  |  |  |  |  | 6 | Install |  | 12-028 |  |  | 12-018 |  |  |  |
| 23213020M |  | Comp Cavity Tests (INSTALL & SYS COMMIS) | milestone | 0d | 2013-12-13 | 2013-12-13 | 281321055, 232113125, 281321050, 281315025, 281315025a |  |  |  | 78d | 16d | 8/5 M-F w/JLAB Holidays ReBaseline |  |  |  |  | 0 | HOVATER C | 1 | 1 | 08-009 | M | BILL M |  |  |  |  | 10-066 |  |  |  |  |  | 6 |  |  | 12-028 |  |  | 12-018 | 23213020M | 13-015 | PR |

Notes:
- 132127001: Steps: Purchase Parts (done); First Article Manufactured (done); First Article Assembled (done); Remainder Manufactured (done); Remainder Assembled (done); Break Out Board Manufactured (done)

| ID | WBS | Activity | Type | Duration | Start | Finish | Predecessors | Complete | Planned start | Planned finish | Resources | Cost | Actual cost | Calculated Remaining Total Cost | MONTHLY EV COST | RESP - Responsibility | STRT%COMP for CM EVM | FNSH%COMP for CM EVM | EVMS Reporting Codes | CAM RESPONSIBLE | CR 08-059 | CR 10-028 | CR 11-055 | CR 12-029 | CR 12-050 | CR 12-028 | Advance Purchase Plan > 500K | CR 08-016 | 12 GEV MAJOR PROCUREMENT CATAGORY | CR 09-012 | CR 10-040 | Remaining Material Cost Based on % Compl | Claimed Material Cost Based on % Complet | Initial Claimed Material Calc | Claimed Material Divider | Milestone Level | LOE Divider | LOE Multiplier | Activities with Steps | CR 12-035 | CR 10-066 | LOE % Pre Calc | LOE % | Installation | CR 12-001 | MARCH!!! | CR 08-010 | CR 12-029A |
| --- | --- | --- | --- | --- | --- | --- | --- | --- | --- | --- | --- | --- | --- | --- | --- | --- | --- | --- | --- | --- | --- | --- | --- | --- | --- | --- | --- | --- | --- | --- | --- | --- | --- | --- | --- | --- | --- | --- | --- | --- | --- | --- | --- | --- | --- | --- | --- | --- |
|  | 4 | **1.3.2.1.4 SYSTEM OPERATION** |  |  |  |  |  |  |  |  |  |  |  |  |  |  |  |  |  |  |  |  |  |  |  |  |  |  |  |  |  |  |  |  |  |  |  |  |  |  |  |  |  |  |  |  |  |  |
|  | 2 | **1.3.2.2 MAGNET POWER** |  |  | 2009-01-22 | 2014-09-30 |  |  |  |  |  |  |  |  |  |  |  |  |  |  |  |  |  |  |  |  |  |  |  |  |  |  |  |  |  |  |  |  |  |  |  |  |  |  |  |  |  |  |
|  | 1 | **1.3.2.2.1 BOX SUPPLIES** |  |  | 2009-01-22 | 2014-09-30 |  |  |  |  |  |  |  |  |  |  |  |  |  |  |  |  |  |  |  |  |  |  |  |  |  |  |  |  |  |  |  |  |  |  |  |  |  |  |  |  |  |  |
| 13221028 |  | Prcrmnt Prep for Box 600/500kW PS - Arc & Septa (Box SUPPLIES) |  | 131d | 2009-01-22 A | 2009-07-28 A | 121221150, 9-090M FS+59d | 100% |  |  | ELEC DES [80 h]; ELEC ENG [160 h] | 13,955.2 | 13,955.2 | 0 | 13955.2 | MERZ B | 1 | 1 | H | BILL M | 08-059 | 10-028 | 11-055 | 12-029F | 12-050F |  |  |  |  |  |  |  |  |  |  |  |  |  |  |  |  |  |  |  |  |  |  |  |
| 13221053 |  | Bid/Award Box Low Power PS - Transport (Box SUPPLIES) |  | 157d | 2009-07-08 A | 2010-02-26 A | 9-100M | 100% |  |  | ELEC ENG [160 h]; ELEC DES [80 h] | 14,229.02 | 14,229.02 | 0 | 14398.4 | MERZ B | 1 | 1 | H | BILL M |  |  |  | 12-029F |  | 12-028F |  |  |  |  |  |  |  |  |  |  |  |  |  |  |  |  |  |  |  |  |  |  |
| 13221003 |  | Bid/Award Box 1000kW PS - Arc (Box SUPPLIES) |  | 143d | 2009-07-28 A | 2010-02-26 A | 9-090M | 100% |  |  | ELEC ENG [160 h]; ELEC DES [80 h] | 14,255.83 | 14,255.83 | 0 | 14398.4 | MERZ B | 1 | 1 | H | BILL M |  |  |  |  |  |  |  |  |  |  |  |  |  |  |  |  |  |  |  |  |  |  |  |  |  |  |  |  |
| 13221030 |  | Vend Fab Box 600/500 kW PS - Original Travel Expenses |  | 1d | 2010-03-01 A | 2010-03-01 A | 9-100M FS+60d, 13221029M | 100% |  |  | TRAVEL | 492.78 |  | 0 | 492.78 | MERZ B | 1 | 1 | P | BILL M |  | 10-028 | 11-055 | 12-029F | 12-050F |  | APP | 08-016 | 3221 | 09-012 | 10-040 |  |  |  |  |  |  |  |  |  |  |  |  |  |  |  |  |  |
| 13221035 |  | Monitor Contract Vend Progress- 600/500kW Box PS Original Labor |  | 1d | 2010-03-01 A | 2010-03-01 A | 13221029M | 100% |  |  | ELEC ENG [17.94 h] | 1,188.88 | 1,188.88 | 0 | 1188.8838 | MERZ B | 1 | 1 | H | BILL M |  | 10-028 | 11-055 | 12-029F | 12-050F |  |  |  |  |  | 10-040 |  |  |  |  |  |  |  |  |  |  |  |  |  |  |  |  |  |
| 13221010N |  | Vend Fab Magnet System Box Power Supplies Peg Point #12 Delivery and Accp of Prod PS (QTY 2) (Frozen Per CR11-055) |  | 358d | 2010-03-18 A | 2011-08-22 A | 9-100M FS+110d | 100% |  |  | PROCUREMENT>$50K 69 NO ESCALATION | 339,253.6 |  | 0 | 339253.6 | MERZ B | 1 | 1 | D | BILL M |  | 10-028 | 11-055 | 12-029F | 12-050F |  |  |  |  |  | 10-040 | 0 | 339253.6 | 33925360 | 100 |  |  |  |  |  |  |  |  |  |  |  |  |  |
| 13221010P |  | Vend Fab Magnet System Box Power Supplies Peg Point #13 Delivery and Accp of Spare Parts (Frozen Per CR11-055) |  | 358d | 2010-03-18 A | 2011-08-22 A | 13221010N FS-365d | 100% |  |  | PROCUREMENT>$50K 69 NO ESCALATION | 92,000 |  | 0 | 92000 | MERZ B | 1 | 1 | D | BILL M |  | 10-028 | 11-055 | 12-029F | 12-050F |  |  |  |  |  | 10-040 | 0 | 92000 | 9200000 | 100 |  |  |  |  |  |  |  |  |  |  |  |  |  |
| 13221004M |  | Award Magnet System Box Power Supplies | milestone | 0d | 2010-03-19 A | 2010-03-19 A | 13221054M, 13221003 | 100% | 2010-04-01 | 2010-04-01 |  |  |  |  | 0 | MERZ B | 1 | 1 | M | BILL M |  |  |  |  |  |  |  |  |  |  |  |  |  |  |  | 6 |  |  |  |  |  |  |  |  |  |  |  |  |
| 13221005 |  | Vend Fab Magnet System Box Power Supplies Oversight FY10 |  | 137d | 2010-03-19 A | 2010-09-30 A | 13221004M FS-137d, 13221035 | 100% |  |  | ELEC ENG [156.4 h]; TRAVEL | 16,710.95 | 10,364.63 | 0 | 16710.948 | MERZ B | 1 | 1 | E | BILL M |  | 10-028 | 11-055 | 12-029F | 12-050F |  | APP | 08-016 | 3221 |  | 10-040 |  |  |  |  |  | 100 | 100 |  |  |  |  |  |  |  |  |  |  |
| 13221010 |  | Vend Fab Magnet System Box Power Supplies Peg Point #1 Preliminary Design Report |  | 41d | 2010-03-19 A | 2010-05-17 A | 13221004M FS-137d | 100% | 2010-03-19 | 2010-05-14 |  |  |  |  | 0 | MERZ B | 1 | 1 | P | BILL M |  | 10-028 | 11-055 | 12-029F | 12-050F |  |  |  |  |  | 10-040 |  |  |  |  |  |  |  |  |  |  |  |  |  |  |  |  |  |
| 13221010A |  | Vend Fab Magnet System Box Power Supplies Peg Point #2 Design Review and Approval |  | 94d | 2010-03-19 A | 2010-07-30 A | 13221010 FS-51d | 100% |  |  | PROCUREMENT>$50K 69 NO ESCALATION; PROCUREMENT<$50K 60 NO ESCALATION | 424,067 |  | 0 | 424067 | MERZ B | 1 | 1 | P | BILL M |  | 10-028 | 11-055 | 12-029F | 12-050F |  |  |  |  |  | 10-040 | 0 | 424067 | 42406700 | 100 |  |  |  |  |  |  |  |  |  |  |  |  |  |
| 13221010B |  | Vend Fab Magnet System Box Power Supplies Peg Point #3 First Article Testing - First Topology (Frozen Per CR11-055) |  | 342d | 2010-03-19 A | 2011-08-01 A | 13221010A FS-73d | 100% |  |  | PROCUREMENT>$50K 69 NO ESCALATION | 169,626.8 |  | 0 | 169626.8 | MERZ B | 1 | 1 | P | BILL M |  | 10-028 | 11-055 | 12-029F | 12-050F |  |  |  |  |  | 10-040 | 0 | 169626.8 | 16962680 | 100 |  |  |  |  |  |  |  |  |  |  |  |  |  |
| 13221010C |  | Vend Fab Magnet System Box Power Supplies Peg Point #4 First Article Testing - All Topologies (Frozen Per CR11-055) |  | 342d | 2010-03-19 A | 2011-08-01 A | 13221010B FS-195d | 100% |  |  | PROCUREMENT>$50K 69 NO ESCALATION | 169,626.8 |  | 0 | 169626.8 | MERZ B | 1 | 1 | P | BILL M |  | 10-028 | 11-055 | 12-029F | 12-050F |  |  |  |  |  | 10-040 | 0 | 169626.8 | 16962680 | 100 |  |  |  |  |  |  |  |  |  |  |  |  |  |
| 13221010D |  | Vend Fab Magnet System Box Power Supplies Peg Point #5 Delivery and Accp of Prod Power Supplies (Frozen Per CR11-055) |  | 342d | 2010-03-19 A | 2011-08-01 A | 13221010C FS-234d | 100% |  |  | PROCUREMENT>$50K 69 NO ESCALATION | 169,626.8 |  | 0 | 169626.8 | MERZ B | 1 | 1 | P | BILL M |  | 10-028 | 11-055 | 12-029F | 12-050F |  |  |  |  |  | 10-040 | 0 | 169626.8 | 16962680 | 100 |  |  |  |  |  |  |  |  |  |  |  |  |  |
| 13221010H |  | Vend Fab Magnet System Box Power Supplies Peg Point #8 Delivery and Accp of Prod Power Supplies (Frozen Per CR11-055) |  | 342d | 2010-03-19 A | 2011-08-01 A | 13221010D FS-257d | 100% |  |  | PROCUREMENT>$50K 69 NO ESCALATION | 424,067 |  | 0 | 424067 | MERZ B | 1 | 1 | P | BILL M |  | 10-028 | 11-055 | 12-029F | 12-050F |  |  |  |  |  | 10-040 | 0 | 424067 | 42406700 | 100 |  |  |  |  |  |  |  |  |  |  |  |  |  |
| 13221029M |  | Award Box 600/500 KW PS (BOX SUPPLIES) | milestone | 0d | 2010-03-19 A | 2010-03-19 A | 9-100M FS+60d, 13221028 | 100% | 2010-04-01 | 2010-04-01 |  |  |  |  | 0 | MERZ B | 1 | 1 | M | BILL M |  | 10-028 | 11-055 | 12-029F | 12-050F |  |  |  |  |  |  |  |  |  |  | 6 |  |  |  |  |  |  |  |  |  |  |  |  |
| 13221098 |  | Procure Extraction YA PS & Shunt Sub assemblies |  | 148d | 2010-03-29 A | 2010-10-25 A | 9-100M | 100% |  |  | PROCUREMENT<$50K 60; ELEC TECH [120 h]; ELEC ENG [80 h] | 32,989.9 | 10,313.18 | 0 | 33279.52 | MERZ B | 1 | 1 | S | BILL M |  | 10-028 |  | 12-029F |  | 12-028F | APP |  |  |  |  | 0 | 22676.72 | 2267672 | 100 |  |  |  | ST | 12-035F |  |  |  |  |  |  |  |  |
| 13221100 |  | Assemble YA PS and Shunt subassemblies |  | 104d | 2010-03-29 A | 2010-08-23 A | 13221099M FS-400d | 100% |  |  | ELEC DES [160 h]; ELEC TECH [480 h]; SUPPLIES & MATERIALS | 33,155.59 | 27,486.4 | 0 | 34030.79 | MERZ B | 1 | 1 | S | BILL M |  | 10-028 |  | 12-029F |  | 12-028F |  |  |  |  |  |  |  |  |  |  |  |  | ST | 12-035F |  |  |  |  |  |  |  |  |
| 13221054M |  | Award Box Low Power PS (BOX SUPPLIES) | milestone | 0d | 2010-04-01 A | 2010-04-01 A | 13221053 | 100% | 2010-05-03 | 2010-05-03 |  |  |  |  | 0 | MERZ B | 1 | 1 | M | BILL M |  |  |  | 12-029F |  | 12-028F |  |  |  |  |  |  |  |  |  | 6 |  |  |  |  |  |  |  |  |  |  |  |  |
| 13221077 |  | Dummy Load Design Re-work / Documentation |  | 64d | 2010-04-26 A | 2010-07-26 A | 9-100M FS+143d | 100% |  |  | ELEC ENG [80 h] | 5,301.6 | 5,301.6 | 0 | 5301.6 | MERZ B | 1 | 1 | H | BILL M |  | 10-028 | 11-055 | 12-029F | 12-050F |  |  |  |  |  | 10-040 |  |  |  |  |  |  |  |  |  | 10-066 |  |  |  |  |  |  |  |
| 13221095 |  | Engineering Oversight - Develop/Conduct Procedures, Q.A. and Training FY10 |  | 111d | 2010-04-26 A | 2010-09-30 A | 9-100M FS+150d | 100% |  |  | ELEC ENG [119 h]; ELEC DES [12.56 h]; ELEC TECH [12.56 h] | 9,002.59 | 9,002.59 | 0 | 9002.5884 | MERZ B | 1 | 1 | H | BILL M |  | 10-028 |  |  |  |  |  |  |  |  | 10-040 |  |  |  |  |  |  |  |  |  |  |  |  |  |  |  |  |  |
| 13221099M |  | Award H-D & Lambertson (2) PS (BOX SUPPLIES) | milestone | 0d | 2010-04-26 A | 2010-04-26 A | 9-100M FS+60d, 13221098 | 100% | 2011-03-29 | 2011-03-29 |  |  |  |  | 0 | MERZ B | 1 | 1 | M | BILL M |  | 10-028 |  | 12-029F |  | 12-028F |  |  |  |  |  |  |  |  |  | 6 |  |  |  | 12-035F |  |  |  |  |  |  |  |  |
| 13221078 |  | Order Dummy Load Parts |  | 11d | 2010-07-26 A | 2010-08-09 A | 13221077 | 100% |  |  | ELEC ENG [40 h]; ELEC DES [40 h] | 4,548.4 | 4,548.4 | 0 | 4548.4 | MERZ B | 1 | 1 | H | BILL M |  | 10-028 | 11-055 | 12-029F | 12-050F |  |  |  |  |  |  |  |  |  |  |  |  |  |  |  | 10-066 |  |  |  |  |  |  |  |
| 13221080 |  | Dummy Load Procurement |  | 92d | 2010-09-01 A | 2011-01-20 A | 13221078 | 100% |  |  | PROCUREMENT<$50K 60 NO ESCALATION FY11 | 82,000 |  | 0 | 82000 | MERZ B | 1 | 1 | D | BILL M |  | 10-028 | 11-055 | 12-029F | 12-050F |  | APP |  |  |  |  | 0 | 82000 | 8200000 | 100 |  |  |  |  |  | 10-066 |  |  |  |  |  |  |  |
| 13221005A |  | Vend Fab Magnet System Box Power Supplies Oversight FY11 |  | 248d | 2010-10-01 A | 2011-09-30 A | 13221005 | 100% |  |  | ELEC ENG [282 h]; TRAVEL | 25,831.93 | 19,283.16 | 0 | 25831.93 | MERZ B | 1 | 1 | E | BILL M |  | 10-028 | 11-055 | 12-029F | 12-050F |  | APP |  | 3221 |  | 10-040 |  |  |  |  |  | 100 | 100 |  |  |  | 8.46774193 | 91.53225806 |  |  |  |  |  |
| 13221095LOE |  | Engineering Oversight - Develop/Conduct Procedures, Q.A. and Training FY11 |  | 248d | 2010-10-01 A | 2011-09-30 A | 13221095 | 100% |  |  | ELEC TECH [31.79 h]; ELEC ENG [302.2 h]; ELEC DES [31.79 h] | 23,580.22 | 23,580.22 | 0 | 23580.2148 | MERZ B | 1 | 1 | E | BILL M |  | 10-028 |  |  |  |  |  |  |  |  |  |  |  |  |  |  | 100 | 100 |  |  |  | 8.46774193 | 91.53225806 |  |  |  |  |  |
| 13221105 |  | Install and Check-out YA & Shunt hardware |  | 142d | 2010-11-15 A | 2011-06-15 A | 13221099M | 100% |  |  | ELEC TECH [160 h]; ELEC ENG [80 h] | 12,313.6 | 12,313.6 | 0 | 12313.6 | MERZ B | 1 | 1 | S | BILL M |  | 10-028 |  | 12-029F |  | 12-028F |  |  |  |  |  |  |  |  |  |  |  |  | ST | 12-035F |  |  |  | Install |  |  |  |  |
| 13221085 |  | Dummy Load - Fabricate Sub Assemblies |  | 105d | 2010-11-22 A | 2011-04-29 A | 13221080 FS-30d | 100% |  |  | ELEC TECH [400 h] | 17,108 | 17,108 | 0 | 17108 | MERZ B | 1 | 1 | S | BILL M |  | 10-028 | 11-055 | 12-029F | 12-050F |  |  |  |  |  |  |  |  |  |  |  |  |  | ST |  | 10-066 |  |  |  |  |  |  |  |
| 13221118 |  | Bid Compnts to Refurb 5 PS (Box SUPPLIES) |  | 281d | 2011-01-04 A | 2012-02-21 A | 9-110M | 100% |  |  | ELEC DES [40 h]; ELEC ENG [80 h] | 7,505.93 | 7,505.93 | 0 | 7428.4 | MERZ B | 1 | 1 | H | BILL M |  | 10-028 |  | 12-029F |  | 12-028F |  |  |  |  |  |  |  |  |  |  |  |  |  |  |  |  |  |  |  |  |  |  |
| 13221090 |  | Dummy Load Assemble Unit #1 |  | 30d | 2011-02-14 A | 2011-03-28 A | 13221085 FS-60d | 100% |  |  | ELEC TECH [280 h]; ELEC DES [40 h]; ELEC ENG [40 h] | 16,668.8 | 16,668.8 | 0 | 16668.8 | MERZ B | 1 | 1 | H | BILL M |  | 10-028 | 11-055 | 12-029F | 12-050F |  |  |  |  |  |  |  |  |  |  |  |  |  |  |  | 10-066 |  |  |  |  |  |  |  |
| 13221092 |  | Dummy Load Assemble Unit #2 |  | 50d | 2011-02-14 A | 2011-04-25 A | 13221090 FS-30d | 100% |  |  | ELEC DES [40 h]; ELEC TECH [280 h]; ELEC ENG [40 h] | 16,668.8 | 16,668.8 | 0 | 16668.8 | MERZ B | 1 | 1 | H | BILL M |  | 10-028 | 11-055 | 12-029F | 12-050F |  |  |  |  |  |  |  |  |  |  |  |  |  |  |  | 10-066 |  |  |  |  |  |  |  |
| 13221093 |  | Rental for Dummy Load Water Skid FY11 |  | 115d | 2011-04-01 A | 2011-09-13 A | 4A-01M FS-20d | 100% |  |  | SUPPLIES & MATERIALS; ELEC ENG [32.11 h] | 60,178.64 | 2,195.68 | 0 | 60178.6418 | MERZ B | 1 | 1 | S | BILL M |  | 10-028 |  |  |  |  |  |  |  |  |  |  |  |  |  |  |  |  | ST |  | 10-066 |  |  |  | 12-001 |  |  |  |
| 13221093a |  | Rental for Dummy Load Water Skid FY12 |  | 115d | 2011-04-01 A | 2011-09-13 A | 13221093 | 100% |  |  | ELEC ENG [7.89 h]; SUPPLIES & MATERIALS | 15,244.14 | 539.52 | 0 | 15261.3384 | MERZ B | 1 | 1 | S | BILL M |  | 10-028 |  |  |  |  |  |  |  |  |  |  |  |  |  |  |  |  | ST |  | 10-066 |  |  |  | 12-001 |  |  |  |
| 13221010J |  | Reverse Entry Per CR 11-055 |  | 5d | 2011-08-01 A | 2011-08-05 A | 9-110M FS+204d | 100% |  |  | PROCUREMENT>$50K 69 NO ESCALATION; ELEC TECH [-160.02 h]; ELEC DES [-40.19 h]; ELEC ENG [-40.19 h]; COMP SCIENT [-16.08 h]; SUPPLIES & MATERIALS | -1,377,708.77 | -12,582.08 |  |  | MERZ B | 1 | 1 | P | BILL M |  | 10-028 | 11-055 |  |  |  |  |  |  |  | 10-040 |  |  |  | 100 |  |  |  |  |  |  |  |  |  |  |  |  |  |
| 13221010K |  | Revised Schedule per CR11-055 Vend Fab Magnet Box Power Supplies 1st Article M1 Topology (T&M PS) |  | 81d | 2011-08-01 A | 2011-11-22 A | 13221010H FS+20d | 100% |  |  | PROCUREMENT>$50K 69 NO ESCALATION | 169,626.8 |  | 0 | 169626.8 | MERZ B | 1 | 1 | D | BILL M |  | 10-028 | 11-055 | 12-029F | 12-050F |  |  |  |  |  | 10-040 | 0 | 169626.8 | 16962680 | 100 |  |  |  |  |  |  |  |  |  |  |  |  |  |
| 13221010L |  | Revised Schedule per CR11-055 Vend Fab Magnet Box Power Supplies Delivery of LAM1C Frozen Per CR12-029 |  | 150d | 2011-08-01 A | 2012-03-12 A | 13221010K FS-65d | 100% |  |  | PROCUREMENT>$50K 69 NO ESCALATION | 73,300 |  | 0 | 73300 | MERZ B | 1 | 1 | D | BILL M |  | 10-028 | 11-055 | 12-029F | 12-050F |  |  |  |  |  | 10-040 | 0 | 73300 | 7330000 | 100 |  |  |  |  |  |  |  |  |  |  |  |  |  |
| 13221010Na |  | Revised Schedule per CR11-055 Vend Fab Magnet Box Power Supplies Delivery of LAM3C Frozen Per CR12-029 |  | 150d | 2011-08-01 A | 2012-03-12 A | 13221010L FS-122d | 100% |  |  | PROCUREMENT>$50K 69 NO ESCALATION | 73,300 |  | 0 | 73300 | MERZ B | 1 | 1 | D | BILL M |  | 10-028 | 11-055 | 12-029F | 12-050F |  |  |  |  |  | 10-040 | 0 | 73300 | 7330000 | 100 |  |  |  |  |  |  |  |  |  |  |  |  |  |
| 13221010Pa |  | Revised Schedule per CR11-055 Vend Fab Magnet Box Power Supplies Delivery of XSEP10 Frozen Per CR12-029 |  | 150d | 2011-08-01 A | 2012-03-12 A | 13221010Na FS-142d | 100% |  |  | PROCUREMENT>$50K 69 NO ESCALATION | 73,300 |  | 0 | 73300 | MERZ B | 1 | 1 | D | BILL M |  | 10-028 | 11-055 | 12-029F | 12-050F |  |  |  |  |  | 10-040 | 0 | 73300 | 7330000 | 100 |  |  |  |  |  |  |  |  |  |  |  |  |  |
| 13221010Q |  | Revised Schedule per CR11-055 Vend Fab Magnet Box Power Supplies Delivery of XSEP8 Frozen Per CR12-029 |  | 150d | 2011-08-01 A | 2012-03-12 A | 13221010P FS-505d, 13221010Pa FS-164d | 100% |  |  | PROCUREMENT>$50K 69 NO ESCALATION | 73,300 |  | 0 | 73300 | MERZ B | 1 | 1 | D | BILL M |  | 10-028 | 11-055 | 12-029F | 12-050F |  |  |  |  |  | 10-040 | 0 | 73300 | 7330000 | 100 |  |  |  |  |  |  |  |  |  |  |  |  |  |
| 13221010R |  | Revised Schedule per CR11-055 Vend Fab Magnet Box Power Supplies Delivery of RSEP9A Frozen Per CR12-029 |  | 150d | 2011-08-01 A | 2012-03-12 A | 13221010Q FS-164d | 100% |  |  | PROCUREMENT>$50K 69 NO ESCALATION | 73,300 |  | 0 | 73300 | MERZ B | 1 | 1 | D | BILL M |  | 10-028 | 11-055 | 12-029 | 12-050F |  |  |  |  |  | 10-040 | 0 | 73300 | 7330000 | 100 |  |  |  |  |  |  |  |  |  |  |  |  |  |
| 13221010S |  | Revised Schedule per CR11-055 Vend Fab Magnet Box Power Supplies Delivery of RSEP8A Frozen Per CR12-029 |  | 150d | 2011-08-01 A | 2012-03-12 A | 13221010R FS-185d | 100% |  |  | PROCUREMENT>$50K 69 NO ESCALATION | 73,300 |  | 0 | 73300 | MERZ B | 1 | 1 | D | BILL M |  | 10-028 | 11-055 | 12-029 | 12-050F |  |  |  |  |  | 10-040 | 0 | 73300 | 7330000 | 100 |  |  |  |  |  |  |  |  |  |  |  |  |  |
| 13221010T |  | Revised Schedule per CR11-055 Vend Fab Magnet Box Power Supplies Delivery of ARC2 Frozen Per CR12-029 |  | 150d | 2011-08-01 A | 2012-03-12 A | 13221010S FS-185d | 100% |  |  | PROCUREMENT>$50K 69 NO ESCALATION | 73,300 |  | 0 | 73300 | MERZ B | 1 | 1 | D | BILL M |  | 10-028 | 11-055 | 12-029 | 12-050F |  |  |  |  |  | 10-040 | 0 | 73300 | 7330000 | 100 |  |  |  |  |  |  |  |  |  |  |  |  |  |
| 13221010U |  | Revised Schedule per CR11-055 Vend Fab Magnet Box Power Supplies Delivery of ARC4 Frozen Per CR12-029 |  | 150d | 2011-08-01 A | 2012-03-12 A | 13221010T FS-207d | 100% |  |  | PROCUREMENT>$50K 69 NO ESCALATION | 73,300 |  | 0 | 73300 | MERZ B | 1 | 1 | D | BILL M |  | 10-028 | 11-055 | 12-029 | 12-050F |  |  |  |  |  | 10-040 | 0 | 73300 | 7330000 | 100 |  |  |  |  |  |  |  |  |  |  |  |  |  |
| 13221010V |  | Revised Schedule per CR11-055 Vend Fab Magnet Box Power Supplies Delivery of ARC5 Frozen Per CR12-029 |  | 150d | 2011-08-01 A | 2012-03-12 A | 13221010U FS-207d | 100% |  |  | PROCUREMENT>$50K 69 NO ESCALATION | 73,300 |  | 0 | 73300 | MERZ B | 1 | 1 | D | BILL M |  | 10-028 | 11-055 | 12-029 | 12-050F |  |  |  |  |  | 10-040 | 0 | 73300 | 7330000 | 100 |  |  |  |  |  |  |  |  |  |  |  |  |  |
| 13221010W |  | Revised Schedule per CR11-055 Vend Fab Magnet Box Power Supplies Delivery of ARC7 Frozen Per CR12-029 |  | 150d | 2011-08-01 A | 2012-03-12 A | 13221010V FS-227d | 100% |  |  | PROCUREMENT>$50K 69 NO ESCALATION | 73,300 |  | 0 | 73300 | MERZ B | 1 | 1 | D | BILL M |  | 10-028 | 11-055 | 12-029 | 12-050F |  |  |  |  |  | 10-040 | 0 | 73300 | 7330000 | 100 |  |  |  |  |  |  |  |  |  |  |  |  |  |
| 13221010X |  | Revised Schedule per CR11-055 Vend Fab Magnet Box Power Supplies Delivery of ARC3 Frozen Per CR12-029 |  | 150d | 2011-08-01 A | 2012-03-12 A | 13221010W FS-227d | 100% |  |  | PROCUREMENT>$50K 69 NO ESCALATION | 73,300 |  | 0 | 73300 | MERZ B | 1 | 1 | D | BILL M |  | 10-028 | 11-055 | 12-029 | 12-050F |  |  |  |  |  | 10-040 | 0 | 73300 | 7330000 | 100 |  |  |  |  |  |  |  |  |  |  |  |  |  |
| 13221010Y |  | Revised Schedule per CR11-055 Vend Fab Magnet Box Power Supplies Delivery of ARC6 Frozen Per CR12-029 |  | 150d | 2011-08-01 A | 2012-03-12 A | 13221010X FS-249d | 100% |  |  | PROCUREMENT>$50K 69 NO ESCALATION | 73,300 |  | 0 | 73300 | MERZ B | 1 | 1 | D | BILL M |  | 10-028 | 11-055 | 12-029 | 12-050F |  |  |  |  |  | 10-040 | 0 | 73300 | 7330000 | 100 |  |  |  |  |  |  |  |  |  |  |  |  |  |
| 13221010Z |  | Revised Schedule per CR11-055 Vend Fab Magnet Box Power Supplies Delivery of ARC10 Frozen Per CR12-029 |  | 150d | 2011-08-01 A | 2012-03-12 A | 13221010Y FS-249d | 100% |  |  | PROCUREMENT>$50K 69 NO ESCALATION | 73,300 |  | 0 | 73300 | MERZ B | 1 | 1 | D | BILL M |  | 10-028 | 11-055 | 12-029 | 12-050F |  |  |  |  |  | 10-040 | 0 | 73300 | 7330000 | 100 |  |  |  |  |  |  |  |  |  |  |  |  |  |
| 13221010Za |  | Revised Schedule per CR11-055 Vend Fab Magnet Box Power Supplies Delivery of ARC8 Frozen Per CR12-029 |  | 150d | 2011-08-01 A | 2012-03-12 A | 13221010Z FS-249d | 100% |  |  | PROCUREMENT>$50K 69 NO ESCALATION | 73,300 |  | 0 | 73300 | MERZ B | 1 | 1 | D | BILL M |  | 10-028 | 11-055 | 12-029 | 12-050F |  |  |  |  |  | 10-040 | 0 | 73300 | 7330000 | 100 |  |  |  |  |  |  |  |  |  |  |  |  |  |
| 13221010Zb |  | Revised Schedule per CR11-055 Vend Fab Magnet Box Power Supplies Delivery of ARC9 Frozen Per CR12-029 |  | 150d | 2011-08-01 A | 2012-03-12 A | 13221010Za FS-272d | 100% |  |  | PROCUREMENT>$50K 69 NO ESCALATION | 73,300 |  | 0 | 73300 | MERZ B | 1 | 1 | D | BILL M |  | 10-028 | 11-055 | 12-029 | 12-050F |  |  |  |  |  | 10-040 | 0 | 73300 | 7330000 | 100 |  |  |  |  |  |  |  |  |  |  |  |  |  |
| 13221010Zc |  | Revised Schedule per CR11-055 Vend Fab Magnet Box Power Supplies Delivery of Final Documentation and Spare Parts |  | 150d | 2011-08-01 A | 2012-03-12 A | 13221010Zb FS-272d | 100% |  |  | PROCUREMENT>$50K 69 NO ESCALATION | 95,074.2 |  | 0 | 95074.2 | MERZ B | 1 | 1 | D | BILL M |  | 10-028 | 11-055 | 12-029 | 12-050F |  |  |  |  |  | 10-040 | 0 | 95074.2 | 9507420 | 100 |  |  |  |  |  |  |  |  |  |  |  |  |  |
| 13221015 |  | Receive & Inpect Magnet System Box Power Supplies (Frozen per CR11-055) |  | 7d | 2011-08-01 A | 2011-08-09 A | 9-110M FS+97d | 100% |  |  | ELEC TECH [79.63 h] | 3,405.78 | 3,405.78 | 0 | 3405.7751 | MERZ B | 1 | 1 | H | BILL M |  | 10-028 | 11-055 | 12-029F | 12-050F |  |  |  |  |  | 10-040 |  |  |  |  |  |  |  |  |  |  |  |  |  |  |  |  |  |
| 13221020 |  | Place/Connect/Check-out Magnet System Box Power Supplies (Frozen per CR11-055) |  | 13d | 2011-08-01 A | 2011-08-17 A | 9-110M FS+191d | 100% |  |  | ELEC TECH [80.39 h]; COMP SCIENT [16.08 h]; SUPPLIES & MATERIALS; ELEC ENG [40.19 h]; ELEC DES [40.19 h] | 10,101.99 | 9,176.3 | 0 | 10101.9902 | MERZ B | 1 | 1 | H | BILL M |  | 10-028 | 11-055 | 12-029F | 12-050F |  |  |  |  |  | 10-040 |  |  |  |  |  |  |  |  |  |  |  |  |  |  |  |  |  |
| 13221115 |  | Test Extraction PS Systems |  | 361d | 2011-08-01 A | 2013-05-13 A | 13221105, 13221100 | 100% | 2011-08-01 | 2013-01-16 | ELEC ENG [40 h]; ELEC TECH [40 h]; COMP SCIENT [40 h] | 7,229.84 | 7,268.8 | 0 | 6989.6 | MERZ B | 1 | 1 | H | BILL M |  | 10-028 |  | 12-029F |  | 12-028F |  |  |  |  |  |  |  |  |  |  |  |  |  | 12-035F |  |  |  |  |  | XX |  |  |
| 13221005B |  | Vend Fab Magnet System Box Power Supplies Oversight FY12 |  | 21d | 2011-10-03 A | 2011-10-31 A | 13221005A | 100% |  |  | ELEC ENG [20 h] | 1,411.2 | 1,411.2 | 0 | 1411.2 | MERZ B | 1 | 1 | E | BILL M |  | 10-028 | 11-055 | 12-029F | 12-050F |  | APP |  | 3221 |  | 10-040 |  |  |  |  |  | 100 | 100 |  |  |  | 100 | 0 |  |  |  |  |  |
| 13221096LOE |  | Engineering Oversight - Develop/Conduct Procedures, Q.A. and Training FY12 |  | 247d | 2011-10-03 A | 2012-09-28 A | 13221095LOE | 100% |  |  | ELEC ENG [301 h]; ELEC DES [31.67 h]; ELEC TECH [31.67 h] | 24,235.81 | 24,235.81 | 0 | 24235.8088 | MERZ B | 1 | 1 | E | BILL M |  | 10-028 |  |  |  |  |  |  |  |  |  |  |  |  |  |  | 100 | 100 |  |  |  | 7.69230769 | 92.3076923 |  |  |  |  |  |
| 13221015a |  | Receive & Inpect Magnet System Box Power Supplies (Revised by CR11-055) Frozen Per CR12-029 |  | 84.73d | 2011-11-01 A | 2012-03-12 A | 13221005B FS-232d, 13221010C, 13221010Zc FS-250d | 100% |  |  | ELEC TECH [17.12 h] | 755.51 | 755.51 | 0 | 755.5056 | MERZ B | 1 | 1 | U | BILL M |  | 10-028 | 11-055 | 12-029 | 12-050F |  |  |  |  |  | 10-040 |  |  |  |  |  |  |  |  |  |  |  |  |  |  |  |  |  |
| 13221020a |  | Place/Connect/Check-out Magnet System Box Power Supplies (Revised by CR11-055) Frozen Per CR12-029 |  | 84.24d | 2011-11-01 A | 2012-03-12 A | 13221015a FS-200d, 13221015 FS-175d, 13224040 | 100% |  |  | ELEC ENG [38.4 h]; ELEC DES [38.4 h]; SUPPLIES & MATERIALS; ELEC TECH [76.8 h]; COMP SCIENT [15.36 h] | 9,958.8 | 9,084.37 | 0 | 9958.784855 | MERZ B | 1 | 1 | U | BILL M |  | 10-028 | 11-055 | 12-029 | 12-050F |  |  |  |  |  | 10-040 |  |  |  |  |  |  |  |  |  |  |  |  |  |  |  |  |  |
| 13221119M |  | Award Components to Refurb 6 PS (BOX SUPPLIES) Frozen Per CR 12-028 | milestone | 0d | 2012-02-28 A | 2012-02-28 A | 13221118 | 100% | 2012-03-27 | 2012-03-27 |  |  |  |  | 0 | MERZ B | 1 | 1 | M | BILL M |  | 10-028 |  | 12-029F |  | 12-028F |  |  |  |  |  |  |  |  |  | 6 |  |  |  |  |  |  |  |  |  |  |  |  |
| 13221021 |  | Reverse Entry Per CR12-029 |  | 8d | 2012-03-01 A | 2012-03-12 A | 9-120M FS+99d | 100% |  |  | PROCUREMENT>$50K 69 NO ESCALATION | -1,194,574.2 |  |  |  | MERZ B | 1 | 1 | Z | BILL M |  | 10-028 | 11-055 | 12-029 |  |  |  |  |  |  | 10-040 |  |  |  | 100 |  |  |  |  |  |  |  |  |  |  |  |  |  |
| 13221022 |  | Procurement Prep for Magnet Box Power Supplies Revised per CR12-029 |  | 121d | 2012-03-01 A | 2012-08-20 A | 9-120M FS+98d | 100% |  |  | ELEC ENG [160 h] | 11,289.6 | 11,289.6 | 0 | 11289.6 | MERZ B | 1 | 1 | H | BILL M |  | 10-028 | 11-055 | 12-029 | 12-050F |  |  |  |  |  | 10-040 |  |  |  |  |  |  |  |  |  |  |  |  |  |  |  |  |  |
| 13221025A |  | Test T&M PS |  | 53d | 2012-03-01 A | 2012-05-14 A | 9-120M FS+100d | 100% |  |  | COMP SCIENT [40 h]; ELEC TECH [80 h]; ELEC ENG [80 h] | 11,800 | 11,800 | 0 | 11800 | MERZ B | 1 | 1 | H | BILL M |  |  |  |  |  | 12-028 |  |  |  |  |  |  |  |  |  |  |  |  |  |  |  |  |  |  |  |  |  |  |
| 13221120 |  | Vend Fab Compnts to Refurb 6 PS (Box SUPPLIES) Frozen Per CR 12-028 |  | 8d | 2012-03-01 A | 2012-03-12 A | 13221119M | 100% |  |  | PROCUREMENT>$50K 69 | 101,694.78 |  | 0 | 101694.78 | MERZ B | 1 | 1 | D | BILL M |  | 10-028 |  | 12-029F |  | 12-028F | APP |  |  |  |  | 0 | 101694.78 | 10169478 | 100 |  |  |  |  |  |  |  |  |  |  |  | 08-010 |  |
| 13221125 |  | Monitor Delivery & Receive PS Compnts (Box SUPPLIES) Frozen Per CR 12-028 |  | 8d | 2012-03-01 A | 2012-03-12 A | 13221119M | 100% |  |  | ELEC ENG [40 h]; ELEC TECH [40 h] | 4,587.6 | 4,587.6 | 0 | 4446 | MERZ B | 1 | 1 | H | BILL M |  | 10-028 |  | 12-029F |  | 12-028F |  |  |  |  |  |  |  |  |  |  |  |  |  |  |  |  |  |  |  |  |  |  |
| 13221125A |  | Reverse Entry Per CR 12-028 |  | 8d | 2012-03-01 A | 2012-03-12 A | 9-120M FS+100d | 100% |  |  | ELEC TECH [-40 h]; ELEC ENG [-40 h]; PROCUREMENT>$50K 69 | -106,140.78 | -4,587.6 |  |  | MERZ B | 1 | 1 | Z | BILL M |  | 10-028 |  |  |  | 12-028 |  |  |  |  |  |  |  |  | 100 |  |  |  |  |  |  |  |  |  |  |  |  |  |
| 13221021A |  | Additional Reverse Entry Per CR12-029A |  | 6d | 2012-04-02 A | 2012-04-09 A | 9-120M FS+121d | 100% |  |  | PROCUREMENT>$50K 69 NO ESCALATION | -169,626.8 |  |  |  | MERZ B | 1 | 1 | P | BILL M |  | 10-028 |  | 12-029 |  |  |  |  |  |  |  |  |  |  | 100 |  |  |  |  |  |  |  |  |  |  |  |  | 12-029A |
| 13221126M |  | Award Arc 1 and Hall A PS | milestone | 0d | 2012-04-02 A | 2012-04-02 A | 9-120M FS+120d | 100% | 2012-05-01 | 2012-05-01 |  |  |  |  | 0 | MERZ B | 1 | 1 | M | BILL M |  | 10-028 |  |  |  | 12-028 |  |  |  |  |  |  |  |  |  | 6 |  |  |  |  |  |  |  |  |  |  |  |  |

Notes:
- 13221098: Steps: First Article Chassis Development (done); Fan Assemblies (done); Bulk PS Procurement (done); Materials for 4 Chassis (done)
- 13221100: Steps: Finalize System Layout (done); Build Assembly Fixtures (done); Assemble/Fabricate 4 Chassis (done); Testing of Assemblies & Sub-assemblies (done)
- 13221105: Steps: Install Equipment in Rack (done); Sub Assembly Test (done); Complete Rack Wiring (done); Power Test Assmbly (done)
- 13221085: Steps: Establish Requiremenents (done); Complete Drawings (done); Build Unit 1 (done); Build Unit 2 (done); Test Units (done)
- 13221090: Corrective Actions: DDM: Added Machine Shop expense / resource ($2060) back into this activity.
- 13221092: Corrective Actions: DDM: Added Machine Shop expense / resource ($2060) back into this activity.
- 13221093: Corrective Actions: DDM: Added Machine Shop expense / resource ($2060) back into this activity. / Steps: Parts (done); Assembly (done); Tower Rental Month 1 (done); Tower Rental Month 2 (done); Tower Rental Month 3 (done); Tower Rental Month 4 (done)
- 13221093a: Corrective Actions: DDM: Added Machine Shop expense / resource ($2060) back into this activity. / Steps: Parts (done); Assembly (done); Tower Rental Month 1 (done); Tower Rental Month 2 (done); Tower Rental Month 3 (done); Tower Rental Month 4 (done)

| ID | Activity | Duration | Start | Finish | Predecessors | Complete | Remaining | Planned start | Planned finish | Total float | Free float | Calendar | Resources | Cost | Actual cost | Remaining Material Cost Based on % Compl | Claimed Material Cost Based on % Complet | Initial Claimed Material Calc | Claimed Material Divider | Calculated Remaining Total Cost | MONTHLY EV COST | RESP - Responsibility | STRT%COMP for CM EVM | FNSH%COMP for CM EVM | Advance Purchase Plan > 500K | CR 08-010 | EVMS Reporting Codes | CAM RESPONSIBLE | CR 10-028 | CR 12-028 | LOE % Pre Calc | LOE % | LOE Divider | LOE Multiplier | CR 12-053 | CR 10-040 | CR 11-055 | CR 12-029 | MARCH!!! | CR 12-050 | CR 13-011 | OPC Allison | CR 12-029A | ReBaseline Actuals Adjustment | BOE NOTES | Original Activity ID Rebaseline | PRIOR MONTH EV COST | BOE Labor | BOE Expenses | BOE Adder | CR 13-015 | Post Rebaseline | BOE Procurement | Obligated Prior to Rebaseline | Temple/Lehman | CR 14-001 | CR 08-052 |
| --- | --- | --- | --- | --- | --- | --- | --- | --- | --- | --- | --- | --- | --- | --- | --- | --- | --- | --- | --- | --- | --- | --- | --- | --- | --- | --- | --- | --- | --- | --- | --- | --- | --- | --- | --- | --- | --- | --- | --- | --- | --- | --- | --- | --- | --- | --- | --- | --- | --- | --- | --- | --- | --- | --- | --- | --- | --- |
| 13221127 | Production & Delivery of Arc 1 and Hall A PS | 233d | 2012-04-16 A | 2013-08-30 A | 13221126M | 100% |  | 2012-04-16 | 2013-03-25 |  |  |  | PROCUREMENT>$50K 69 NO ESCALATION FY13 | 150,000 |  | 0 | 150000 | 15000000 | 100 | 75000 | 150000 | MERZ B | 1 | 1 | APP | 08-010 | D | BILL M | 10-028 | 12-028 |  |  |  |  |  |  |  |  |  |  |  |  |  |  |  |  |  |  |  |  |  |  |  |  |  |  |  |
| 13221128 | Monitor Production of Arc 1 and Hall A PS FY12 | 116d | 2012-04-16 A | 2012-09-28 A | 13221126M | 100% |  | 2012-04-16 | 2012-09-27 |  |  |  | ELEC ENG [67.73 h] | 4,779.03 | 4,830.16 |  |  |  |  | 0 | 4779.0288 | MERZ B | 1 | 1 |  |  | E | BILL M | 10-028 | 12-028 | 30 | 70 | 100 | 100 | 12-053 |  |  |  |  |  |  |  |  |  |  |  |  |  |  |  |  |  |  |  |  |  |  |
| 13221026 | Magnet Box Power Supply Original Vendor Refund | 16d | 2012-05-01 A | 2012-05-22 A | 9-120M FS+120d | 100% |  |  |  |  |  |  | PROCUREMENT>$50K 69; PROCUREMENT<$50K 60 | -149,000 |  |  |  |  | 100 |  |  | MERZ B | 1 | 1 |  |  | D | BILL M | 10-028 |  |  |  |  |  |  | 10-040 | 11-055 | 12-029 |  |  |  |  |  |  |  |  |  |  |  |  |  |  |  |  |  |  |  |
| 13221022a | Magnet Box Power Supply Contract Oversight FY12 | 92d | 2012-05-21 A | 2012-09-28 A | 13221022 FS-30d | 100% |  |  |  |  |  |  | ELEC ENG [200 h]; TRAVEL | 18,112 | 14,112 |  |  |  |  | 0 | 18112 | MERZ B | 1 | 1 |  |  | E | BILL M | 10-028 |  | 20.65217391 | 79.34782608 | 100 | 100 |  | 10-040 | 11-055 | 12-029 |  |  |  |  |  |  |  |  |  |  |  |  |  |  |  |  |  |  |  |
| 13221130 | Remove and Shuffle Box PS | 173d | 2012-05-21 A | 2013-05-13 A | 2-02M, 13221128a FS-120d, 13221120, 13221127 FS-210d, 13221125 | 100% |  | 2012-05-21 | 2013-02-01 |  |  |  | SKLLD TRADE [80 h]; ELEC TECH [160 h] | 9,882.51 | 9,930.18 |  |  |  |  | 0 | 9736.8 | MERZ B | 1 | 1 |  |  | H | BILL M | 10-028 | 12-028 |  |  |  |  |  |  |  | 12-029F | XX |  |  |  |  |  |  |  |  |  |  |  |  |  |  |  |  |  |  |
| 13221022D | Vend Fab Magnet Box Power Supplies Peg Point #1 - Design Review (Kick-off Meeting) | 21d | 2012-08-24 A | 2013-02-08 A | 13221022 FS+66d | 100% |  | 2013-02-01 | 2013-03-04 |  |  |  | PROCUREMENT>$50K 69 NO ESCALATION; PROCUREMENT<$50K 60 NO ESCALATION | 173,494 |  | 0 | 173494 | 17349400 | 100 | 0 | 173494 | MERZ B | 1 | 1 |  |  | P | BILL M | 10-028 |  |  |  |  |  |  | 10-040 | 11-055 | 12-029 | XX | 12-050 | 13-011 |  |  |  |  |  |  |  |  |  |  |  |  |  |  |  |  |
| 13221023 | Vend Fab Magnet Box Power Supplies Peg Point #1A - Receipt of Materials | 167d | 2012-08-24 A | 2013-07-15 A | 13221022D FS-105d | 100% |  | 2012-08-24 | 2013-04-30 |  |  |  | PROCUREMENT>$50K 69 NO ESCALATION; PROCUREMENT<$50K 60 NO ESCALATION | 346,988 |  | 0 | 346988 | 34698800 | 100 | 0 | 346988 | MERZ B | 1 | 1 |  |  | D | BILL M | 10-028 |  |  |  |  |  |  | 10-040 | 11-055 | 12-029 |  | 12-050 | 13-011 |  |  |  |  |  |  |  |  |  |  |  |  |  |  |  |  |
| 13221023A | Vend Fab Magnet Box Power Supplies Peg Point #2 - First Power Supply (ARC 2) Delivered to JLab | 231d | 2012-08-24 A | 2013-07-15 A | 13221023 FS-167d | 100% |  | 2012-08-24 | 2013-07-31 |  |  |  |  |  |  |  |  |  |  |  | 0 | MERZ B | 1 | 1 |  |  | P | BILL M | 10-028 |  |  |  |  |  |  | 10-040 | 11-055 | 12-029 |  | 12-050 |  |  |  |  |  |  |  |  |  |  |  |  |  |  |  |  |  |
| 13221023B | Vend Fab Magnet Box Power Supplies Peg Point #3 - First Power Supply (ARC 2) Accepted, Tested and Production Start | 253d | 2012-08-24 A | 2013-08-30 A | 13221023A FS-231d | 100% |  |  |  |  |  |  | PROCUREMENT>$50K 69 NO ESCALATION | 57,000 |  | 0 | 57000 | 5700000 | 100 | 57000 | 57000 | MERZ B | 1 | 1 |  |  | P | BILL M | 10-028 |  |  |  |  |  |  | 10-040 | 11-055 | 12-029 |  | 12-050 |  |  |  |  |  |  |  |  |  |  |  |  |  |  |  |  |  |
| 13221022b | Magnet Box Power Supply Contract Oversight FY13 | 248d | 2012-10-01 A | 2013-08-30 A | 13221022a | 100% |  | 2012-10-01 | 2013-09-30 |  |  |  | ELEC ENG [280 h]; TRAVEL | 26,578.2 | 20,386.8 |  |  |  |  | 4502.34708 | 24434.8402 | MERZ B | 1 | 1 |  |  | E | BILL M | 10-028 |  | 8.06451612 | 91.93548387 | 100 | 100 |  | 10-040 | 11-055 | 12-029 |  |  |  | OPC A |  |  |  |  |  |  |  |  |  |  |  |  |  |  |  |
| 13221097LOE | Engineering Oversight - Develop/Conduct Procedures, Q.A. and Training FY13 | 31d | 2012-10-01 A | 2012-11-12 A | 13221096LOE | 100% |  |  |  |  |  |  | ELEC ENG [37.8 h]; ELEC DES [3.98 h]; ELEC TECH [3.98 h] | 3,140.91 | 3,140.91 |  |  |  |  | 0 | 3140.9048 | MERZ B | 1 | 1 |  |  | E | BILL M | 10-028 |  | 25.80645161 | 74.19354838 | 100 | 100 |  |  |  |  |  |  |  |  |  |  |  |  |  |  |  |  |  |  |  |  |  |  |  |
| 13221128a | Monitor Production of Arc 1 and Hall A PS FY13 | 23d | 2012-10-01 A | 2012-10-31 A | 13221128 FS-50d | 100% |  |  |  |  |  |  | ELEC ENG [12.27 h] | 893.38 | 893.38 |  |  |  |  | 0 | 893.3787 | MERZ B | 1 | 1 |  |  | E | BILL M | 10-028 | 12-028 | 0 |  | 100 | 100 | 12-053 |  |  |  |  |  |  |  |  |  |  |  |  |  |  |  |  |  |  |  |  |  |  |
| 13221024 | Receive & Inpect Magnet System Box Power Supplies (Revised by CR12-029) | 215d | 2013-07-15 A | 2013-08-30 A | 13221023A, 13221023 FS-320d | 100% |  | 2013-09-03 | 2014-07-16 |  |  |  | ELEC TECH [11.34 h] | 531.34 | 516.42 |  |  |  |  | 4692.62376 | 516.4236 | MERZ B | 1 | 1 |  |  | U | BILL M | 10-028 |  |  |  |  |  |  | 10-040 | 11-055 | 12-029 |  | 12-050 |  | OPC A |  |  |  |  |  |  |  |  |  |  |  |  |  |  |  |
| 13221133 | Receive, Inspect and Install Arc 1 and Hall A PS | 9d | 2013-07-15 A | 2013-08-30 A | 13221127 FS-15d | 100% |  | 2013-09-04 | 2013-09-16 |  |  |  | ELEC TECH [160 h]; SKLLD TRADE [80 h] | 10,048 | 10,048 |  |  |  |  | 5024 | 10048 | MERZ B | 1 | 1 |  |  | H | BILL M | 10-028 | 12-028 |  |  |  |  |  |  |  |  |  |  |  |  |  |  |  |  |  |  |  |  |  |  |  |  |  |  |  |
| 13221024a | Place/Connect/Check-out Magnet System Box Power Supplies (Revised by CR12-029) | 215d | 2013-08-12 A | 2013-08-30 A | 13221024 FS-210d | 100% |  | 2013-09-03 | 2014-07-16 |  |  |  | ELEC TECH [95.14 h]; COMP SCIENT [19.03 h]; SUPPLIES & MATERIALS; ELEC ENG [47.57 h]; ELEC DES [47.57 h] | 13,064.2 | 11,563.54 |  |  |  |  | 160998.9004 | 12730.099649 | MERZ B | 1 | 1 |  |  | U | BILL M | 10-028 |  |  |  |  |  |  | 10-040 | 11-055 | 12-029 |  | 12-050 |  | OPC A | 12-029A |  |  |  |  |  |  |  |  |  |  |  |  |  |  |
| 13221025 | Test Magnet System Box Power Supplies w/Dummy Load | 215d | 2013-08-30 A | 2013-08-30 A | 13221092, 13221024a FS-210d, 3A-23M, 13221020 FS-180d, 13221020a FS+14.6d | 100% |  | 2013-09-03 | 2014-07-16 |  |  |  | ELEC TECH [71.64 h]; ELEC ENG [35.62 h]; ELEC DES [35.62 h] | 7,935.29 | 7,712.49 |  |  |  |  | 138246.4 | 7715.8772 | MERZ B | 1 | 1 |  |  | U | BILL M | 10-028 |  |  |  |  |  |  | 10-040 | 11-055 | 12-029 |  | 12-050 |  | OPC A |  |  |  |  |  |  |  |  |  |  |  |  |  |  |  |
| 13221135 | Test Arc 1 and Hall A PS w/ Dummy Load | 10d | 2013-08-30 A | 2013-08-30 A | 13221133, 13221130 FS-20d | 100% |  | 2013-09-20 | 2013-10-03 |  |  |  | ELEC TECH [196 h]; ELEC DES [64 h]; ELEC ENG [40 h] | 15,318.89 | 15,173.92 |  |  |  |  | 15173.92 | 15173.92 | MERZ B | 1 | 1 |  |  | H | BILL M | 10-028 | 12-028 |  |  |  |  |  |  |  | 12-029F |  |  |  | OPC A |  |  |  |  |  |  |  |  |  |  |  |  |  |  |  |
| 13221140 | Re-Baseline Actuals Adjustment | 1d | 2013-08-30 A | 2013-08-30 A |  | 100% |  | 2013-09-03 | 2013-09-03 |  |  |  | PROCUREMENT>$50K 69 NO ESCALATION | -32,719.25 |  |  |  |  | 100 |  |  |  |  |  |  |  |  |  |  |  |  |  |  |  |  |  |  |  |  |  |  |  |  | ADJ |  |  |  |  |  |  |  |  |  |  |  |  |  |
| 23221022b | Magnet Box Power Supply Contract Oversight FY13 | 20d | 2013-09-03 A | 2013-09-30 A | 9-130M FS+228d | 100% |  | 2013-10-01 | 2013-10-28 |  |  | 8/5 M-F w/JLAB Holidays ReBaseline | ELEC ENG [32.21 h]; TRAVEL | 3,761.94 | 2,345.21 |  |  |  |  |  | 0 | MERZ B | 1 | 1 |  |  | E | BILL M | 10-028 |  |  |  | 100 | 100 |  | 10-040 | 11-055 | 12-029 |  |  |  |  |  |  | Extra effort to keep on schedule | 23221022b | 3687.2101 | EJ | EJ | NO | 13-015 | PR |  |  |  |  |  |
| 23221023C | Vend Fab Magnet Box Power Supplies Peg Point #4 - ARC 3, 4, 5, 6 and LAM 1 Delivered and accepted at JLab | 62d | 2013-09-03 A | 2013-11-27 | 9-130M FS+228d | 40% | 19d | 2013-10-01 | 2014-01-08 | 293d | 43d | 8/5 M-F w/JLAB Holidays ReBaseline | PROCUREMENT>$50K 69 NO ESCALATION | 290,775 |  | 174465 | 116310 | 11631000 | 100 |  | 116310 | MERZ B | 1 | 1 |  |  | D | BILL M | 10-028 |  |  |  |  |  |  | 10-040 | 11-055 | 12-029 |  | 12-050 |  |  |  |  |  | 23221023C |  |  |  |  | 13-015 | PR | OB | OB |  |  |  |
| 23221023D | Vend Fab Magnet Box Power Supplies Peg Point #4 *** Delivery Incentive Bonus****** | 62d | 2013-09-03 A | 2013-11-27 | 23221023C FS-62d |  | 19d | 2013-10-01 | 2014-01-08 | 250d | 0d | 8/5 M-F w/JLAB Holidays ReBaseline | PROCUREMENT>$50K 69 NO ESCALATION | 80,000 |  | 80000 | 0 | 0 | 100 |  | 0 | MERZ B | 1 | 1 |  |  | D | BILL M | 10-028 |  |  |  |  |  |  | 10-040 | 11-055 | 12-029 |  | 12-050 |  |  |  |  |  | 23221023D |  |  |  |  | 13-015 | PR | OB | OB |  |  |  |
| 23221023F | Vend Fab Magnet Box Power Supplies Peg Point #5 - ARC 7, 8, 9, 10, RSEP 8 and XSEP 10 Delivered and accepted at JLab | 161d | 2013-09-03 A | 2014-04-30 | 23221023D FS-62d |  | 118d | 2013-10-01 | 2014-05-29 | 207d | 43d | 8/5 M-F w/JLAB Holidays ReBaseline | PROCUREMENT>$50K 69 NO ESCALATION | 377,630 |  | 377630 | 0 | 0 | 100 |  | 0 | MERZ B | 1 | 1 |  |  | D | BILL M | 10-028 |  |  |  |  |  |  | 10-040 | 11-055 | 12-029 |  | 12-050 |  |  |  |  |  | 23221023F |  |  |  |  | 13-015 | PR | OB | OB |  |  |  |
| 23221023G | Vend Fab Magnet Box Power Supplies Peg Point #5 *** Delivery Incentive Bonus****** | 161d | 2013-09-03 A | 2014-04-30 | 23221023F FS-161d |  | 118d | 2013-10-01 | 2014-05-29 | 164d | 0d | 8/5 M-F w/JLAB Holidays ReBaseline | PROCUREMENT>$50K 69 NO ESCALATION | 80,000 |  | 80000 | 0 | 0 | 100 |  | 0 | MERZ B | 1 | 1 |  |  | D | BILL M | 10-028 |  |  |  |  |  |  | 10-040 | 11-055 | 12-029 |  | 12-050 |  |  |  |  |  | 23221023G |  |  |  |  | 13-015 | PR | OB | OB |  |  |  |
| 23221023H | Vend Fab Magnet Box Power Supplies Peg Point #6 - LAM 3, XSEP 8 and RSEP 9 Delivered and accepted at JLab | 182d | 2013-09-03 A | 2014-05-30 | 23221023G FS-161d |  | 139d | 2013-10-01 | 2014-06-27 | 283d | 43d | 8/5 M-F w/JLAB Holidays ReBaseline | PROCUREMENT>$50K 69 NO ESCALATION | 104,565 |  | 104565 | 0 | 0 | 100 |  | 0 | MERZ B | 1 | 1 |  |  | D | BILL M | 10-028 |  |  |  |  |  |  | 10-040 | 11-055 | 12-029 |  | 12-050 |  |  |  |  |  | 23221023H |  |  |  |  | 13-015 | PR | OB | OB |  |  |  |
| 23221023J | Vend Fab Magnet Box Power Supplies Peg Point #6 *** Delivery Incentive Bonus****** | 182d | 2013-09-03 A | 2014-05-30 | 23221023H FS-182d |  | 139d | 2013-10-01 | 2014-06-27 | 240d | 43d | 8/5 M-F w/JLAB Holidays ReBaseline | PROCUREMENT>$50K 69 NO ESCALATION | 40,000 |  | 40000 | 0 | 0 | 100 |  | 0 | MERZ B | 1 | 1 |  |  | D | BILL M | 10-028 |  |  |  |  |  |  | 10-040 | 11-055 | 12-029 |  | 12-050 |  |  |  |  |  | 23221023J |  |  |  |  | 13-015 | PR | OB | OB |  |  |  |
| 23221023K | Vend Fab Magnet Box Power Supplies Peg Point #7 Acceptance Test at JLab | 246d | 2013-09-03 A | 2014-08-29 | 23221023J FS-182d |  | 203d | 2013-10-01 | 2014-09-29 | 197d | 43d | 8/5 M-F w/JLAB Holidays ReBaseline | PROCUREMENT>$50K 69 NO ESCALATION | 384,488 |  | 384488 | 0 | 0 | 100 |  | 0 | MERZ B | 1 | 1 |  |  | D | BILL M | 10-028 |  |  |  |  |  |  | 10-040 | 11-055 | 12-029 |  | 12-050 |  |  |  |  |  | 23221023K |  |  |  |  | 13-015 | PR | OB | OB |  |  |  |
| 23221023L | Vend Fab Magnet Box Power Supplies Peg Point #8 Delivery of Spares | 246d | 2013-09-03 A | 2014-08-29 | 23221023K FS-246d |  | 203d | 2013-10-01 | 2014-09-29 | 154d |  | 8/5 M-F w/JLAB Holidays ReBaseline | PROCUREMENT>$50K 69 NO ESCALATION | 53,800 |  | 53800 | 0 | 0 | 100 |  | 0 | MERZ B | 1 | 1 |  |  | D | BILL M | 10-028 |  |  |  |  |  |  | 10-040 | 11-055 | 12-029 |  | 12-050 |  |  |  |  |  | 23221023L |  |  |  |  | 13-015 | PR | OB | OB |  |  |  |
| 23221024 | Receive & Inpect Magnet System Box Power Supplies Part A FY13 (FY14 @ 23221029) | 20d | 2013-09-03 A | 2013-11-27 | 9-130M FS+228d | 40% | 19d | 2013-10-01 | 2013-10-28 | 82d | 0d | 8/5 M-F w/JLAB Holidays ReBaseline | ELEC TECH [10.68 h] | 501.85 | 343.06 |  |  |  |  |  | 194.54688 | MERZ B | 1 | 1 |  |  | U | BILL M | 10-028 |  |  |  |  |  |  | 10-040 | 11-055 | 12-029 |  | 12-050 |  |  |  |  |  | 23221024 |  | PE | EJ |  | 13-015 | PR |  |  |  |  |  |
| 23221024b | Place/Connect Magnet System Box Power Supplies Part A Procurement | 62d | 2013-09-03 A | 2013-11-27 | 23221024a FS-193d | 20% | 19d | 2013-10-01 | 2014-01-08 | 39d | 0d | 8/5 M-F w/JLAB Holidays ReBaseline | ELEC TECH; COMP SCIENT; SUPPLIES & MATERIALS; ELEC ENG; ELEC DES; PROCUREMENT<$50K 60 [1584 unit] | 434.55 |  | 347.64 | 86.91 | 8691 | 100 |  | 21.7275 | MERZ B | 1 | 1 |  |  | U | BILL M | 10-028 |  |  |  |  |  |  | 10-040 | 11-055 | 12-029 |  | 12-050 |  |  | 12-029A |  |  | 23221024a | 65.1825 | PE | EJ |  | 13-015 | PR |  | OB | LR13 |  |  |
| 23221024c | Place/Connect Magnet System Box Power Supplies Part A Labor/Expenses FY13 | 20d | 2013-09-03 A | 2013-11-27 | 23221024a FS-193d | 20% | 19d | 2013-10-01 | 2013-10-28 | 39d | 0d | 8/5 M-F w/JLAB Holidays ReBaseline | ELEC TECH [114.25 h]; COMP SCIENT [22.85 h]; SUPPLIES & MATERIALS; ELEC ENG [57.12 h]; ELEC DES [57.12 h] | 15,584.05 | 9,794.84 |  |  |  |  |  | 578.73261285 | MERZ B | 1 | 1 |  |  | U | BILL M | 10-028 |  |  |  |  |  |  | 10-040 | 11-055 | 12-029 |  | 12-050 |  |  | 12-029A |  |  | 23221024a | 2271.25383855 | PE | EJ |  | 13-015 | PR |  |  | LR13 |  |  |
| 23221024d | Place/Connect Magnet System Box Power Supplies Part A Labor/Expenses FY14 | 42d | 2013-09-03 A | 2013-11-27 | 23221024c FS-62d, 23221024a FS-193d | 20% | 19d | 2013-10-29 | 2014-01-08 | 39d | 0d | 8/5 M-F w/JLAB Holidays ReBaseline | ELEC TECH [239.91 h]; COMP SCIENT [47.98 h]; SUPPLIES & MATERIALS; ELEC ENG [119.96 h]; ELEC DES [119.96 h] | 32,810.38 | 20,569.02 |  |  |  |  |  | 1824.5589173 | MERZ B | 1 | 1 |  |  | U | BILL M | 10-028 |  |  |  |  |  |  | 10-040 | 11-055 | 12-029 |  | 12-050 |  |  | 12-029A |  |  | 23221024a | 4921.5567519 | PE | EJ |  | 13-015 | PR |  |  | LR13 | 14-001 |  |
| 23221029 | Receive & Inpect Magnet System Box Power Supplies Part A FY14 (FY13 @ 23221024) | 42d | 2013-09-03 A | 2013-11-27 | 23221024 FS-62d | 40% | 19d | 2013-10-01 | 2013-11-27 | 82d | 0d | 8/5 M-F w/JLAB Holidays ReBaseline | ELEC TECH [22.42 h] | 1,053.52 | 720.18 |  |  |  |  |  | 421.40632 | MERZ B | 1 | 1 |  |  | U | BILL M | 10-028 |  |  |  |  |  |  | 10-040 | 11-055 | 12-029 |  | 12-050 |  |  |  |  |  | 23221024 |  | PE | EJ |  | 13-015 | PR |  |  |  | 14-001 |  |
| 23221127 | Production & Delivery of Arc 1 and Hall A PS | 34d | 2013-09-03 A | 2013-10-21 A | 9-130M FS+228d | 100% |  | 2013-10-01 | 2013-11-15 |  |  | 8/5 M-F w/JLAB Holidays ReBaseline | PROCUREMENT>$50K 69 NO ESCALATION | 70,875 |  | 0 | 70875 | 7087500 | 100 |  | 70875 | MERZ B | 1 | 1 | APP | 08-010 | U | BILL M | 10-028 | 12-028 |  |  |  |  |  |  |  |  |  |  |  |  |  |  |  | 23221127 |  |  |  |  | 13-015 | PR | OB | OB |  |  |  |
| 23221133 | Receive, Inspect and Install Arc 1 and Hall A PS FY13 | 59d | 2013-09-03 A | 2013-11-22 | 23221127 FS-34d | 50% | 16d | 2013-10-01 | 2014-01-03 | 149d | 39d | 8/5 M-F w/JLAB Holidays ReBaseline | SKLLD TRADE [13.56 h]; ELEC TECH [27.12 h] | 1,757.38 | 1,262.42 |  |  |  |  |  | 0 | MERZ B | 1 | 1 |  |  | U | BILL M | 10-028 | 12-028 |  |  |  |  |  |  |  |  |  |  |  |  |  |  |  | 23221133 | 851.568 | PE | EJ |  | 13-015 | PR |  |  |  |  |  |
| 23221133a | Receive, Inspect and Install Arc 1 and Hall A PS FY14 | 39d | 2013-09-03 A | 2013-11-22 | 23221127 FS-34d, 23221133 FS-59d | 50% | 16d | 2013-10-01 | 2013-11-22 | 149d | 39d | 8/5 M-F w/JLAB Holidays ReBaseline | SKLLD TRADE [26.44 h]; ELEC TECH [52.88 h] | 3,426.62 | 2,461.52 |  |  |  |  |  | 0 | MERZ B | 1 | 1 |  |  | U | BILL M | 10-028 | 12-028 |  |  |  |  |  |  |  |  |  |  |  |  |  |  |  | 23221133 | 1713.312 | PE | EJ |  | 13-015 | PR |  |  |  | 14-001 |  |
| 23221022c | Magnet Box Power Supply Contract Oversight FY14 | 163d | 2013-10-01 A | 2014-06-02 | 23221022b | 14% | 140d | 2013-11-01 | 2014-07-03 | 17d |  | 8/5 M-F w/JLAB Holidays ReBaseline | ELEC ENG [160 h]; TRAVEL | 18,212.2 | 1,696.19 |  |  |  |  |  | 2569.74142 | MERZ B | 1 | 1 |  |  | E | BILL M | 10-028 |  | 85.88957055 | 14.11042944 | 100 | 100 |  | 10-040 | 11-055 | 12-029 |  |  |  |  |  |  | Extra effort to keep on schedule | 23221022c |  | EJ | EJ | NO | 13-015 | PR |  |  |  | 14-001 |  |
| 23221140LOE | Proj Admin ongoing FY14 Part A | 42d | 2013-10-01 A | 2013-11-27 | 232111914LOE | 55% | 19d | 2013-11-01 | 2014-01-13 | 58d | 0d | 8/5 M-F w/JLAB Holidays ReBaseline | SR STAFF [74.82 h] | 9,002.34 | 4,929.85 |  |  |  |  |  | 4929.68269824 | MERZ B | 1 | 1 |  |  | E | BILL M |  |  | 45.23809523 | 54.76190476 | 100 | 100 |  |  |  |  |  |  |  |  |  |  |  | 23221140LOE |  | EJ |  |  | 13-015 | PR |  |  |  | 14-001 | 08-052 |
| 23221023Da | DeObligation of Vend Fab Magnet Box Power Supplies Peg Point #4 *** Delivery Incentive Bonus **** | 1d | 2013-11-27 | 2013-11-27 | 23221023D FS-1d |  |  |  |  | 263d |  | 8/5 M-F w/JLAB Holidays ReBaseline | PROCUREMENT>$50K 69 NO ESCALATION | -80,000 |  | -80000 | 0 | 0 | 100 |  | 0 | MERZ B | 1 | 1 |  |  | D | BILL M | 10-028 |  |  |  |  |  |  | 10-040 | 11-055 | 12-029 |  | 12-050 |  |  |  |  |  | 23221023D |  |  |  |  | 13-015 | PR | OB |  |  |  |  |
| 23221024a | Receive & Inpect Magnet System Box Power Supplies Part B | 131d | 2013-12-02 | 2014-06-16 | 23221024, 23221029 |  |  |  |  | 82d | 43d | 8/5 M-F w/JLAB Holidays ReBaseline | ELEC TECH [59.45 h] | 2,793.56 |  |  |  |  |  |  | 0 | MERZ B | 1 | 1 |  |  | U | BILL M | 10-028 |  |  |  |  |  |  | 10-040 | 11-055 | 12-029 |  | 12-050 |  |  |  |  |  | 23221024 |  | PE | EJ |  | 13-015 | PR |  |  |  | 14-001 |  |
| 23221024ba | Place/Connect Magnet System Box Power Supplies Part B | 136d | 2013-12-02 | 2014-06-23 | 23221024c, 23221024d, 23221024b |  |  |  |  | 39d |  | 8/5 M-F w/JLAB Holidays ReBaseline | ELEC TECH [659.87 h]; COMP SCIENT [131.97 h]; SUPPLIES & MATERIALS; ELEC ENG [329.94 h]; ELEC DES [329.94 h] | 90,524.13 |  |  |  |  |  |  | 0 | MERZ B | 1 | 1 |  |  | U | BILL M | 10-028 |  |  |  |  |  |  | 10-040 | 11-055 | 12-029 |  | 12-050 |  |  | 12-029A |  |  | 23221024a |  | PE | EJ |  | 13-015 | PR |  |  | LR13 | 14-001 |  |
| 23221140LOEa | Proj Admin ongoing FY14 Part B | 205d | 2013-12-02 | 2014-09-30 | 23221140LOE |  |  |  |  | 58d |  | 8/5 M-F w/JLAB Holidays ReBaseline | SR STAFF [310.41 h] | 37,348.53 |  |  |  |  |  |  | 0 | MERZ B | 1 | 1 |  |  | E | BILL M |  |  | 100 | 0 | 100 | 100 |  |  |  |  |  |  |  |  |  |  |  | 23221140LOE |  | EJ |  |  | 13-015 | PR |  |  |  | 14-001 | 08-052 |
| 23221023Ga | Partial DeObligation of Vend Fab Magnet Box Power Supplies Peg Point #5 *** Delivery Incentive Bonus****** | 1d | 2014-04-30 | 2014-04-30 | 23221023G FS-1d |  |  |  |  | 164d |  | 8/5 M-F w/JLAB Holidays ReBaseline | PROCUREMENT>$50K 69 NO ESCALATION | -40,000 |  | -40000 | 0 | 0 | 100 |  | 0 | MERZ B | 1 | 1 |  |  | D | BILL M | 10-028 |  |  |  |  |  |  | 10-040 | 11-055 | 12-029 |  | 12-050 |  |  |  |  |  | 23221023G |  |  |  |  | 13-015 | PR | OB |  |  |  |  |

| ID | WBS | Activity | Type | Duration | Start | Finish | Predecessors | Complete | Remaining | Planned start | Planned finish | Total float | Free float | Calendar | Resources | Cost | Actual cost | MONTHLY EV COST | RESP - Responsibility | STRT%COMP for CM EVM | FNSH%COMP for CM EVM | EVMS Reporting Codes | CAM RESPONSIBLE | CR 10-028 | CR 12-028 | CR 12-029 | Calculated Remaining Total Cost | Remaining Material Cost Based on % Compl | Claimed Material Cost Based on % Complet | Initial Claimed Material Calc | Claimed Material Divider | Activities with Steps | CR 11-001 | CR 12-001 | OPC Allison | MARCH!!! | CR 12-053 | ReBaseline Actuals Adjustment | Original Activity ID Rebaseline | PRIOR MONTH EV COST | BOE Labor | BOE Expenses | CR 13-015 | Post Rebaseline | CR 14-001 | Obligated Prior to Rebaseline |
| --- | --- | --- | --- | --- | --- | --- | --- | --- | --- | --- | --- | --- | --- | --- | --- | --- | --- | --- | --- | --- | --- | --- | --- | --- | --- | --- | --- | --- | --- | --- | --- | --- | --- | --- | --- | --- | --- | --- | --- | --- | --- | --- | --- | --- | --- | --- |
|  | 2 | **1.3.2.2.2 SHUNTS** |  |  | 2010-04-26 | 2014-04-18 |  |  |  |  |  |  |  |  |  |  |  |  |  |  |  |  |  |  |  |  |  |  |  |  |  |  |  |  |  |  |  |  |  |  |  |  |  |  |  |  |
| 13222000M |  | Start Shunt Work | milestone | 0d | 2010-04-26 A | 2010-04-26 A | 9-100M FS+150d | 100% |  | 2010-05-13 | 2010-05-13 |  |  |  |  |  |  | 0 | MERZ B | 1 | 1 | M | BILL M | 10-028 | 12-028F | 12-029F |  |  |  |  |  |  |  |  |  |  |  |  |  |  |  |  |  |  |  |  |
| 13222005 |  | Engineering, Drafting and Software - Single Channel Shunt Chassis |  | 128d | 2010-04-26 A | 2010-10-25 A | 9-100M FS+95d, 13222000M | 100% |  |  |  |  |  |  | ELEC ENG [40 h]; ELEC DES [40 h]; COMP SCIENT [40 h] | 7,042.9 | 7,042.9 | 7013.2 | MERZ B | 1 | 1 | H | BILL M | 10-028 | 12-028F | 12-029F | 0 |  |  |  |  |  |  |  |  |  |  |  |  |  |  |  |  |  |  |  |
| 13222015 |  | Labor and Expenses - Single Channel Shunt Chassis |  | 143d | 2010-04-26 A | 2010-11-15 A | 13222005 FS-65d | 100% |  |  |  |  |  |  | ELEC TECH [16 h]; MSHOP | 3,167.93 | 667.93 | 3163.2 | MERZ B | 1 | 1 | H | BILL M | 10-028 | 12-028F | 12-029F | 0 |  |  |  |  |  |  |  |  |  |  |  |  |  |  |  |  |  |  |  |
| 13222020 |  | Procurements Parts and Boards - Single Channel Shunt Chassis |  | 143d | 2010-04-26 A | 2010-11-15 A | 13222015 FS-65d | 100% |  |  |  |  |  |  | PROCUREMENT<$50K 60 | 20,200 |  | 20200 | MERZ B | 1 | 1 | S | BILL M | 10-028 | 12-028F | 12-029F | 0 | 0 | 20200 | 2020000 | 100 | ST |  |  |  |  |  |  |  |  |  |  |  |  |  |  |
| 13222040 |  | Engineering and Drafting - Shunt Resistor Plates |  | 16d | 2010-04-26 A | 2010-05-17 A | 9-100M FS+95d | 100% |  |  |  |  |  |  | ELEC ENG [40 h]; ELEC DES [24 h] | 3,789.36 | 3,789.36 | 3789.36 | MERZ B | 1 | 1 | H | BILL M | 10-028 |  | 12-029F | 0 |  |  |  |  |  |  |  |  |  |  |  |  |  |  |  |  |  |  |  |
| 13222045 |  | Labor and Expenses - Shunt Resistor Plates FY10 |  | 21d | 2010-04-26 A | 2010-05-24 A | 13222040 FS-10d | 100% |  |  |  |  |  |  | MSHOP; ELEC TECH [23.33 h] | 5,342.03 | 967.03 | 5342.0285 | MERZ B | 1 | 1 | H | BILL M | 10-028 |  | 12-029F | 0 |  |  |  |  |  | 11-001 |  |  |  |  |  |  |  |  |  |  |  |  |  |
| 13222045a |  | Labor and Expenses - Shunt Resistor Plates FY11 |  | 21d | 2010-04-26 A | 2010-05-24 A | 13222045 FS-60d | 100% |  |  |  |  |  |  | MSHOP; ELEC TECH [16.67 h] | 3,915.66 | 690.97 | 3937.6659 | MERZ B | 1 | 1 | H | BILL M | 10-028 |  | 12-029F | 0 |  |  |  |  |  | 11-001 |  |  |  |  |  |  |  |  |  |  |  |  |  |
| 13222050 |  | Procurement (Parts) - Shunt Resistor Plates |  | 103d | 2010-04-26 A | 2010-09-20 A | 13222045a FS-65d | 100% |  |  |  |  |  |  | PROCUREMENT<$50K 60 NO ESCALATION FY11 | 28,000 |  | 28000 | MERZ B | 1 | 1 | S | BILL M | 10-028 |  | 12-029F | 0 | 0 | 28000 | 2800000 | 100 | ST |  |  |  |  |  |  |  |  |  |  |  |  |  |  |
| 13222055 |  | Assembly and Testing - Shunt Resistor Plates |  | 146d | 2010-05-24 A | 2010-12-20 A | 13222050 FS-30d, 13222045a FS-50d | 100% |  |  |  |  |  |  | ELEC TECH [210 h] | 8,808.92 | 8,808.92 | 8981.7 | MERZ B | 1 | 1 | U | BILL M | 10-028 |  | 12-029F | 0 |  |  |  |  |  |  |  |  |  |  |  |  |  |  |  |  |  |  |  |
| 13222105 |  | Engineering, Drafting and Software - 75 Amp Shunt Upgrade |  | 108d | 2010-05-24 A | 2010-10-25 A | 9-110M FS-80d | 100% |  |  |  |  |  |  | ELEC DES [8 h]; COMP SCIENT [80 h]; ELEC ENG [32 h] | 7,467.1 | 7,467.1 | 7666.96 | MERZ B | 1 | 1 | H | BILL M | 10-028 | 12-028F | 12-029F | 0 |  |  |  |  |  |  |  |  |  |  |  |  |  |  |  |  |  |  |  |
| 13222025 |  | Assembly and Testing - Single Channel Shunt Chassis FY10 |  | 34d | 2010-07-26 A | 2010-09-10 A | 13222020 FS-55d | 100% |  |  |  |  |  |  | ELEC TECH [25.71 h] | 1,065.68 | 1,065.68 | 1065.6795 | MERZ B | 1 | 1 | U | BILL M | 10-028 | 12-028F | 12-029F | 0 |  |  |  |  |  | 11-001 |  |  |  |  |  |  |  |  |  |  |  |  |  |
| 13222025a |  | Assembly and Testing - Single Channel Shunt Chassis FY11 |  | 34d | 2010-07-26 A | 2010-09-10 A | 13222020 FS-55d | 100% |  |  |  |  |  |  | ELEC TECH [334.29 h] | 13,856.32 | 13,856.32 | 14297.5833 | MERZ B | 1 | 1 | U | BILL M | 10-028 | 12-028F | 12-029F | 0 |  |  |  |  |  | 11-001 |  |  |  |  |  |  |  |  |  |  |  |  |  |
| 13222115 |  | Procurement (Parts) - 75 Amp Shunt Upgrade |  | 17d | 2010-08-06 A | 2010-08-30 A | 13222110 FS-120d | 100% |  |  |  |  |  |  | PROCUREMENT<$50K 60 | 309.57 |  | 309.57 | MERZ B | 1 | 1 | D | BILL M | 10-028 | 12-028F | 12-029F | 0 | 0 | 309.57 | 30957 | 100 |  |  |  |  |  |  |  |  |  |  |  |  |  |  |  |
| 13222070 |  | Engineering, Drafting and Software - Track Regulator and 30/80 Frozen per CR12-028 |  | 323d | 2010-11-15 A | 2012-03-12 A | 9-110M | 100% |  |  |  |  |  |  | ELEC ENG [160 h]; ELEC DES [160 h]; COMP SCIENT [40 h] | 21,539.43 | 21,539.43 | 21316.4 | MERZ B | 1 | 1 | H | BILL M | 10-028 |  | 12-029F | 0 |  |  |  |  |  |  |  |  |  |  |  |  |  |  |  |  |  |  |  |
| 13222165 |  | Engineering and Drafting - 12GEV Shunt Shuffle |  | 470d | 2010-12-01 A | 2012-10-22 A | 9-120M FS-300d | 100% |  |  |  |  |  |  | ELEC ENG [160 h]; ELEC DES [160 h] | 19,128.67 | 19,128.67 | 19371.2 | MERZ B | 1 | 1 | H | BILL M | 10-028 | 12-028 | 12-029F | 0 |  |  |  |  |  |  |  |  |  |  |  |  |  |  |  |  |  |  |  |
| 13222080 |  | Procurement (Parts) - Track Regulator and 30/80 Frozen per CR12-028 |  | 228d | 2011-04-11 A | 2012-03-12 A | 13222075 FS-115d | 100% |  |  |  |  |  |  | PROCUREMENT<$50K 60 | 34,362.27 |  | 34362.27 | MERZ B | 1 | 1 | S | BILL M | 10-028 |  | 12-029F | 0 | 0 | 34362.27 | 3436227 | 100 | ST |  |  |  |  |  |  |  |  |  |  |  |  |  |  |
| 13222075 |  | Oversight (Labor) - Track Regulator and 30/80 Frozen per CR12-028 |  | 225d | 2011-04-14 A | 2012-03-12 A | 13222070 FS-90d | 100% |  |  |  |  |  |  | ELEC TECH [40 h] | 1,736.43 | 1,736.43 | 1710.8 | MERZ B | 1 | 1 | H | BILL M | 10-028 |  | 12-029F | 0 |  |  |  |  |  |  |  |  |  |  |  |  |  |  |  |  |  |  |  |
| 13222110 |  | Oversight (Labor) - 75 Amp Shunt Upgrade |  | 54d | 2011-05-09 A | 2011-07-25 A | 13222105 | 100% |  |  |  |  |  |  | ELEC TECH [40 h] | 1,710.8 | 1,710.8 | 1710.8 | MERZ B | 1 | 1 | H | BILL M | 10-028 | 12-028F | 12-029F | 0 |  |  |  |  |  |  |  |  |  |  |  |  |  |  |  |  |  |  |  |
| 13222120 |  | Modifications and Testing - 75 Amp Shunt Upgrade FY11 |  | 17d | 2011-05-23 A | 2011-06-15 A | 13222115 | 100% |  |  |  |  |  |  | ELEC TECH [62.48 h] | 2,672.27 | 2,672.27 | 2672.2696 | MERZ B | 1 | 1 | U | BILL M | 10-028 | 12-028F | 12-029F | 0 |  |  |  |  |  |  | 12-001 |  |  |  |  |  |  |  |  |  |  |  |  |
| 13222120a |  | Modifications and Testing - 75 Amp Shunt Upgrade FY12 |  | 17d | 2011-05-23 A | 2011-06-15 A | 13222120 | 100% |  |  |  |  |  |  | ELEC TECH [101.52 h] | 4,342.01 | 4,342.01 | 4480.0776 | MERZ B | 1 | 1 | U | BILL M | 10-028 | 12-028F | 12-029F | 0 |  |  |  |  |  |  | 12-001 |  |  |  |  |  |  |  |  |  |  |  |  |
| 13222140 |  | Update Machine Documentation - 75 Amp Shunt Upgrade Part A |  | 370d | 2011-05-23 A | 2012-11-12 A | 13222125 FS-295d | 100% |  |  |  |  |  |  | ELEC TECH [8 h]; ELEC DES [8 h] | 753.34 | 753.34 | 757.12 | MERZ B | 1 | 1 | H | BILL M | 10-028 |  | 12-029F | 0 |  |  |  |  |  |  |  | OPC A |  |  |  |  |  |  |  |  |  |  |  |
| 13222125 |  | Installation and Testing - 75 Amp Shunt Upgrade Part A |  | 305d | 2011-08-03 A | 2012-10-22 A | 9-120M FS-21d, 13222120a | 100% |  |  |  |  |  |  | ELEC TECH [80 h] | 3,521.34 | 3,521.34 | 3530.4 | MERZ B | 1 | 1 | H | BILL M | 10-028 |  | 12-029F | 0 |  |  |  |  |  |  |  | OPC A |  |  |  |  |  |  |  |  |  |  |  |
| 13222060 |  | Installation - Shunt Resistor Plates Frozen per CR12-028 |  | 8d | 2012-03-01 A | 2012-03-12 A | 13222055, 4A-01M | 100% |  |  |  |  |  |  | ELEC TECH [80 h] | 3,530.4 | 3,530.4 | 3421.6 | MERZ B | 1 | 1 | U | BILL M | 10-028 |  | 12-029F | 0 |  |  |  |  |  |  |  |  |  |  |  |  |  |  |  |  |  |  |  |
| 13222061 |  | Reverse Entry per CR12-028 |  | 8d | 2012-03-01 A | 2012-03-12 A | 9-120M FS+100d | 100% |  |  |  |  |  |  | ELEC TECH [-492 h]; COMP SCIENT [-20 h]; ELEC ENG [-80 h]; PROCUREMENT<$50K 60; ELEC DES [-80 h] | -46,454.87 | -32,709.96 |  | MERZ B | 1 | 1 | Z | BILL M | 10-028 | 12-028 |  |  |  |  |  | 100 |  |  |  |  |  |  |  |  |  |  |  |  |  |  |  |
| 13222065 |  | Update Machine Documentation - Shunt Resistor Plates Frozen per CR12-028 |  | 8d | 2012-03-01 A | 2012-03-12 A | 13222060 | 100% |  |  |  |  |  |  | ELEC TECH [24 h] | 1,059.12 | 1,059.12 | 1026.48 | MERZ B | 1 | 1 | H | BILL M | 10-028 |  | 12-029F | 0 |  |  |  |  |  |  |  |  |  |  |  |  |  |  |  |  |  |  |  |
| 13222085 |  | Assembly and Testing - Track Regulator and 30/80 Frozen per CR12-028 |  | 8d | 2012-03-01 A | 2012-03-12 A | 13222080 | 100% |  |  |  |  |  |  | ELEC TECH [272 h] | 12,003.36 | 12,003.36 | 11633.44 | MERZ B | 1 | 1 | U | BILL M | 10-028 |  | 12-029F | 0 |  |  |  |  |  |  |  |  |  |  |  |  |  |  |  |  |  |  |  |
| 13222090 |  | Installation and Testing - Track Regulator and 30/80 Frozen per CR12-028 |  | 8d | 2012-03-01 A | 2012-03-12 A | 13222085 | 100% |  |  |  |  |  |  | ELEC TECH [80 h] | 3,530.4 | 3,530.4 | 3421.6 | MERZ B | 1 | 1 | U | BILL M | 10-028 |  | 12-029F | 0 |  |  |  |  |  |  |  |  |  |  |  |  |  |  |  |  |  |  |  |
| 13222100 |  | Data Entry/Paperwork - Track Regulator and 30/80 Frozen per CR12-028 |  | 8d | 2012-03-01 A | 2012-03-12 A | 13222090 | 100% |  |  |  |  |  |  | ELEC TECH [16 h] | 706.08 | 706.08 | 684.32 | MERZ B | 1 | 1 | H | BILL M | 10-028 |  | 12-029F | 0 |  |  |  |  |  |  |  |  |  |  |  |  |  |  |  |  |  |  |  |
| 13222070A |  | Engineering, Drafting and Software - Track Regulator and 30/80 Revised Per CR 12-028 |  | 261d | 2012-03-13 A | 2013-08-30 A | 9-120M FS+100d | 100% |  | 2012-03-13 | 2013-03-29 |  |  |  | COMP SCIENT [60 h]; ELEC ENG [80 h]; ELEC DES [80 h] | 13,822.44 | 13,891.08 | 13622.8 | MERZ B | 1 | 1 | H | BILL M | 10-028 | 12-028 |  | 6811.4 |  |  |  |  |  |  |  |  |  |  |  |  |  |  |  |  |  |  |  |
| 13222145 |  | Engineering (Design) - Shunt Adder System Removal |  | 10d | 2012-05-01 A | 2012-05-14 A | 9-110M FS+165d, 2-02M | 100% |  |  |  |  |  |  | ELEC TECH [24 h] | 1,059.12 | 1,059.12 | 1026.48 | MERZ B | 1 | 1 | H | BILL M | 10-028 |  | 12-029F | 0 |  |  |  |  |  |  |  |  |  |  |  |  |  |  |  |  |  |  |  |
| 13222150 |  | Component Removal - Shunt Adder System Removal |  | 6d | 2012-05-11 A | 2012-05-19 A | 13222145, 2-02M FS+14d | 100% |  | 2012-05-11 | 2012-05-18 |  |  |  | ELEC TECH [40 h] | 1,765.2 | 1,765.2 | 1765.2 | MERZ B | 1 | 1 | U | BILL M | 10-028 |  | 12-029F | 0 |  |  |  |  |  |  |  |  |  |  |  |  |  |  |  |  |  |  |  |
| 13222155 |  | Reconfiguration and Testing - Shunt Adder System Removal |  | 8d | 2012-05-20 A | 2012-05-31 A | 13222150 | 100% |  | 2012-05-21 | 2012-05-31 |  |  |  | ELEC TECH [36 h] | 1,588.68 | 1,588.68 | 1588.68 | MERZ B | 1 | 1 | U | BILL M | 10-028 |  | 12-029F | 0 |  |  |  |  |  |  |  |  |  |  |  |  |  |  |  |  |  |  |  |
| 13222170 |  | Pull and Modify - 12GEV Shunt Shuffle |  | 151d | 2012-06-05 A | 2013-08-30 A | 13222165 FS-70d | 100% |  | 2012-06-05 | 2013-01-14 |  |  |  | ELEC ENG [20 h]; ELEC TECH [200 h] | 10,384.45 | 10,476.93 | 10237.2 | MERZ B | 1 | 1 | U | BILL M | 10-028 | 12-028 | 12-029F | 2047.44 |  |  |  |  |  |  |  |  | XX |  |  |  |  |  |  |  |  |  |  |
| 13222200 |  | Engineering, Drafting and Software - 25 Amp Shunts |  | 36d | 2012-07-02 A | 2012-08-20 A | 9-120M FS+205d | 100% |  |  |  |  |  |  | ELEC ENG [80 h] | 5,644.8 | 5,644.8 | 5644.8 | MERZ B | 1 | 1 | H | BILL M | 10-028 | 12-028 | 12-029F | 0 |  |  |  |  |  |  |  |  |  |  |  |  |  |  |  |  |  |  |  |
| 13222205 |  | Procurement Labor - 25 Amp Shunts FY12 |  | 36d | 2012-07-02 A | 2012-08-20 A | 13222200 FS-70d | 100% |  |  |  |  |  |  | ELEC ENG [29.43 h] | 2,076.58 | 2,076.58 | 2076.5808 | MERZ B | 1 | 1 | H | BILL M | 10-028 | 12-028 | 12-029F | 0 |  |  |  |  |  |  |  | OPC A |  | 12-053 |  |  |  |  |  |  |  |  |  |
| 13222205a |  | Procurement Labor - 25 Amp Shunts FY13 |  | 36d | 2012-07-02 A | 2012-08-20 A | 13222205 | 100% |  |  |  |  |  |  | ELEC ENG [10.57 h] | 745.82 | 745.82 | 769.6017 | MERZ B | 1 | 1 | H | BILL M | 10-028 | 12-028 | 12-029F | 0 |  |  |  |  |  |  |  |  |  | 12-053 |  |  |  |  |  |  |  |  |  |
| 13222210 |  | Procurements - 25 Amp Shunts |  | 11d | 2012-08-06 A | 2012-08-20 A | 13222200, 13222205a FS-87d | 100% |  |  |  |  |  |  | PROCUREMENT<$50K 60 NO ESCALATION FY13 | 6,000 |  | 6000 | MERZ B | 1 | 1 | D | BILL M | 10-028 | 12-028 | 12-029F | 0 | 0 | 6000 | 600000 | 100 |  |  |  | OPC A |  |  |  |  |  |  |  |  |  |  |  |
| 13222160 |  | Update Machine Documentation - Shunt Adder System RemovalNew Activity |  | 6d | 2012-09-10 A | 2012-09-17 A | 13222155 FS+15d | 100% |  |  |  |  |  |  | ELEC TECH [16 h] | 706.08 | 706.08 | 706.08 | MERZ B | 1 | 1 | H | BILL M | 10-028 |  | 12-029F | 0 |  |  |  |  |  |  |  |  |  |  |  |  |  |  |  |  |  |  |  |
| 13222175 |  | Clean and Modify Racks - 12GEV Shunts |  | 114d | 2012-09-10 A | 2013-08-30 A | 13222170 FS-30d | 100% |  | 2012-09-10 | 2013-02-28 |  |  |  | ELEC TECH [80 h] | 3,628.36 | 3,636.24 | 3530.4 | MERZ B | 1 | 1 | U | BILL M | 10-028 | 12-028 | 12-029F | 882.6 |  |  |  |  |  |  |  |  | XX |  |  |  |  |  |  |  |  |  |  |
| 13222215 |  | Modification - 25 Amp Shunt Upgrade |  | 68d | 2012-09-10 A | 2012-12-15 A | 13222210 FS-5d | 100% |  | 2012-09-10 | 2012-12-14 |  |  |  | ELEC ENG [40 h]; ELEC TECH [160 h] | 10,129.19 | 10,129.19 | 10198.8 | MERZ B | 1 | 1 | U | BILL M | 10-028 | 12-028 | 12-029F | 0 |  |  |  |  |  |  |  | OPC A |  |  |  |  |  |  |  |  |  |  |  |
| 13222195 |  | Update Machine Documentation - 12GEV Shunts |  | 150d | 2012-09-17 A | 2013-08-30 A | 13222190 FS-250d | 100% |  | 2012-09-17 | 2013-04-26 |  |  |  | ELEC ENG [20 h]; ELEC DES [40 h] | 3,533.71 | 3,536.4 | 3541 | MERZ B | 1 | 1 | H | BILL M | 10-028 | 12-028 | 12-029F | 1770.5 |  |  |  |  |  |  |  | OPC A |  |  |  |  |  |  |  |  |  |  |  |
| 13222030 |  | Installation and Testing - Single Channel Shunt Chassis |  | 75d | 2012-10-08 A | 2013-08-30 A | 9-130M, 2-02M, 13222025a | 100% |  | 2012-10-08 | 2013-01-31 |  |  |  | ELEC TECH [80 h] | 3,643.2 | 3,643.2 | 3643.2 | MERZ B | 1 | 1 | H | BILL M | 10-028 | 12-028 | 12-029F | 1821.6 |  |  |  |  |  |  |  | OPC A | XX |  |  |  |  |  |  |  |  |  |  |
| 13222035 |  | Data Entry / Paperwork - Single Channel Shunt Chassis |  | 75d | 2012-10-08 A | 2013-08-30 A | 13222030 FS-80d | 100% |  | 2012-10-08 | 2013-01-31 |  |  |  | COMP SCIENT [8 h]; ELEC DES [8 h] | 958.64 | 958.64 | 958.64 | MERZ B | 1 | 1 | H | BILL M | 10-028 | 12-028 | 12-029F | 479.32 |  |  |  |  |  |  |  | OPC A | XX |  |  |  |  |  |  |  |  |  |  |
| 13222063 |  | Installation - Shunt Resistor Plates Part A |  | 53d | 2012-11-12 A | 2012-12-17 A | 9-130M, 13417030 FS-15d | 100% |  | 2012-11-12 | 2013-02-05 |  |  |  | ELEC TECH [120 h] | 5,464.8 | 5,464.8 | 5295.6 | MERZ B | 1 | 1 | H | BILL M | 10-028 | 12-028 |  | 0 |  |  |  |  |  |  |  |  |  |  |  |  |  |  |  |  |  |  |  |
| 13222180 |  | Reinstall Chassis' in 12 GEV Shunts |  | 69d | 2012-11-12 A | 2013-08-30 A | 13222170 FS-30d, 13222175 FS-60d | 100% |  | 2012-11-12 | 2013-02-28 |  |  |  | ELEC TECH [80 h] | 3,643.2 | 3,643.2 | 3530.4 | MERZ B | 1 | 1 | U | BILL M | 10-028 | 12-028 | 12-029F | 1765.2 |  |  |  |  |  |  |  | OPC A | XX |  |  |  |  |  |  |  |  |  |  |
| 13222064 |  | Installation - Shunt Resistor Plates Part B |  | 64d | 2012-12-03 A | 2013-08-30 A | 13222063 | 100% |  | 2013-03-01 | 2013-05-30 |  |  |  | ELEC TECH [280 h] | 12,751.2 | 12,751.2 | 12751.2 | MERZ B | 1 | 1 | U | BILL M | 10-028 | 12-028 |  | 1275.12 |  |  |  |  |  |  |  | OPC A |  |  |  |  |  |  |  |  |  |  |  |
| 13222067 |  | Update Machine Documentation - Shunt Resistor Plates Revised Per CR 12-028 |  | 86d | 2012-12-03 A | 2013-08-30 A | 13222064 FS-95d | 100% |  | 2013-01-02 | 2013-05-03 |  |  |  | ELEC TECH [24 h] | 1,092.96 | 1,092.96 | 1092.96 | MERZ B | 1 | 1 | H | BILL M | 10-028 | 12-028 |  | 546.48 |  |  |  |  |  |  |  | OPC A |  |  |  |  |  |  |  |  |  |  |  |
| 13222220 |  | Installation and Testing - 25 Amp Shunt Upgrade |  | 59d | 2013-01-07 A | 2013-08-30 A | 13222215 | 100% |  | 2013-03-14 | 2013-06-05 |  |  |  | ELEC ENG [40 h]; ELEC TECH [40 h] | 4,734 | 4,734 | 4734 | MERZ B | 1 | 1 | U | BILL M | 10-028 | 12-028 | 12-029F | 3313.8 |  |  |  |  |  |  |  | OPC A |  |  |  |  |  |  |  |  |  |  |  |
| 13222075A |  | Oversight (Labor) - Track Regulator and 30/80 Revised Per CR 12-028 |  | 59d | 2013-01-28 A | 2013-08-30 A | 13222070A FS-50d | 100% |  | 2013-03-05 | 2013-05-24 |  |  |  | ELEC TECH [20 h] | 910.8 | 910.8 | 910.8 | MERZ B | 1 | 1 | H | BILL M | 10-028 | 12-028 |  | 455.4 |  |  |  |  |  |  |  | OPC A |  |  |  |  |  |  |  |  |  |  |  |
| 13222080A |  | Procurement (Parts) - Track Regulator and 30/80 Revised Per CR 12-028 |  | 59d | 2013-04-01 A | 2013-08-30 A | 13222075A FS-59d | 100% |  | 2013-05-01 | 2013-07-24 |  |  |  | PROCUREMENT<$50K 60 | 14,183.37 |  | 14183.37 | MERZ B | 1 | 1 | D | BILL M | 10-028 | 12-028 |  | 3545.8425 | 0 | 14183.37 | 1418337 | 100 |  |  |  | OPC A |  |  |  |  |  |  |  |  |  |  |  |
| 13222085A |  | Assembly and Testing - Track Regulator and 30/80 Revised Per CR 12-028 |  | 59d | 2013-06-03 A | 2013-08-30 A | 13222080A FS-40d | 100% |  | 2013-07-01 | 2013-09-23 |  |  |  | ELEC TECH [160 h]; ELEC ENG [80 h]; ELEC DES [32 h] | 14,779.04 | 14,779.04 | 14779.04 | MERZ B | 1 | 1 | U | BILL M | 10-028 | 12-028 |  | 7389.52 |  |  |  |  |  |  |  | OPC A |  |  |  |  |  |  |  |  |  |  |  |
| 13222130 |  | Installation and Testing - 75 Amp Shunt Upgrade Part B |  | 73d | 2013-07-08 A | 2013-08-30 A | 9-130M, 13222120a | 100% |  | 2013-08-01 | 2013-11-12 |  |  |  | ELEC TECH [40 h] | 1,846.23 | 1,821.6 | 1821.6 | MERZ B | 1 | 1 | H | BILL M | 10-028 | 12-028 |  | 910.8 |  |  |  |  |  |  |  | OPC A |  |  |  |  |  |  |  |  |  |  |  |
| 13222095 |  | Installation and Testing - Track Regulator and 30/80 Revised Per CR 12-028 |  | 14d | 2013-08-30 A | 2013-08-30 A | 13222085A | 100% |  | 2013-09-26 | 2013-10-15 |  |  |  | ELEC ENG [40 h]; ELEC TECH [40 h] | 4,852.48 | 4,734 | 4734 | MERZ B | 1 | 1 | U | BILL M | 10-028 | 12-028 |  | 4734 |  |  |  |  |  |  |  | OPC A |  |  |  |  |  |  |  |  |  |  |  |
| 13222100A |  | Data Entry/Paperwork - Track Regulator and 30/80 Revised Per CR 12-028 |  | 12d | 2013-08-30 A | 2013-08-30 A | 13222095 | 100% |  | 2013-10-16 | 2013-10-31 |  |  |  | ELEC DES [16 h] | 860.48 | 833.92 | 833.92 | MERZ B | 1 | 1 | H | BILL M | 10-028 | 12-028 |  | 833.92 |  |  |  |  |  |  |  | OPC A |  |  |  |  |  |  |  |  |  |  |  |
| 13222142 |  | Update Machine Documentation - 75 Amp Shunt Upgrade Part B |  | 12d | 2013-08-30 A | 2013-08-30 A | 13222130 | 100% |  | 2013-11-13 | 2013-12-02 |  |  |  | ELEC DES [8 h] | 430.24 | 416.96 | 416.96 | MERZ B | 1 | 1 | H | BILL M | 10-028 | 12-028 |  | 416.96 |  |  |  |  |  |  |  | OPC A |  |  |  |  |  |  |  |  |  |  |  |
| 13222185 |  | New Screens for 12 GEV Shunts |  | 5d | 2013-08-30 A | 2013-08-30 A | 9-130M FS+220d, 13222165 | 100% |  | 2013-09-03 | 2013-09-09 |  |  |  | COMP SCIENT [40 h] | 2,708.4 | 2,708.4 | 2624.8 | MERZ B | 1 | 1 | H | BILL M | 10-028 |  | 12-029F | 2624.8 |  |  |  |  |  |  |  |  |  |  |  |  |  |  |  |  |  |  |  |
| 13222190 |  | Reconfiguration and Testing - 12GEV Shunts |  | 40d | 2013-08-30 A | 2013-08-30 A | 13224087, 13224085B, 13222180, 13222185, 13224085C | 100% |  | 2013-09-30 | 2013-11-22 |  |  |  | ELEC TECH [160 h] | 7,512.6 | 7,286.4 | 7286.4 | MERZ B | 1 | 1 | U | BILL M | 10-028 | 12-028 | 12-029F | 7286.4 |  |  |  |  |  |  |  | OPC A |  |  |  |  |  |  |  |  |  |  |  |
| 13222230 |  | Drafting (Update Machine Drawings) |  | 44d | 2013-08-30 A | 2013-08-30 A | 13222220 | 100% |  | 2013-09-30 | 2013-12-02 |  |  |  | ELEC ENG [8 h]; ELEC DES [80 h] | 4,900 | 4,752.08 | 4752.08 | MERZ B | 1 | 1 | H | BILL M | 10-028 | 12-028 | 12-029F | 4752.08 |  |  |  |  |  |  |  | OPC A |  |  |  |  |  |  |  |  |  |  |  |
| 13222240 |  | Re-Baseline Actuals Adjustment |  | 1d | 2013-08-30 A | 2013-08-30 A |  | 100% |  | 2013-09-03 | 2013-09-03 |  |  |  | PROCUREMENT>$50K 69 NO ESCALATION | 174,521.87 |  | 174521.87 |  |  |  |  |  |  |  |  |  | 0 | 174521.87 | 17452187 | 100 |  |  |  |  |  |  | ADJ |  |  |  |  |  |  |  |  |
| 23222030 |  | Installation and Testing - Single Channel Shunt Chassis FY13 |  | 44d | 2013-09-03 A | 2013-09-23 A | 9-130M FS+228d | 100% |  | 2013-10-01 | 2013-12-03 |  |  | 8/5 M-F w/JLAB Holidays ReBaseline | ELEC TECH [9.09 h] | 427.14 | 413.96 | 0 | MERZ B | 1 | 1 | U | BILL M | 10-028 | 12-028 | 12-029F |  |  |  |  |  |  |  |  |  |  |  |  | 23222030 | 413.9586 | PE | EJ | 13-015 | PR |  |  |
| 23222030a |  | Installation and Testing - Single Channel Shunt Chassis FY14 |  | 24d | 2013-09-03 A | 2013-09-23 A | 23222030 | 100% |  | 2013-10-01 | 2013-11-01 |  |  | 8/5 M-F w/JLAB Holidays ReBaseline | ELEC TECH [10.91 h] | 512.66 | 496.84 | 0 | MERZ B | 1 | 1 | U | BILL M | 10-028 | 12-028 | 12-029F |  |  |  |  |  |  |  |  |  |  |  |  | 23222030 | 512.6609 | PE | EJ | 13-015 | PR | 14-001 |  |
| 23222035 |  | Data Entry / Paperwork - Single Channel Shunt Chassis FY13 |  | 44d | 2013-09-03 A | 2013-09-23 A | 23222030 FS-44d, 23222030a | 100% |  | 2013-10-01 | 2013-12-03 |  |  | 8/5 M-F w/JLAB Holidays ReBaseline | COMP SCIENT [0.91 h]; ELEC DES [0.91 h] | 112.52 | 109.05 | 0 | MERZ B | 1 | 1 | H | BILL M | 10-028 | 12-028 | 12-029F |  |  |  |  |  |  |  |  |  |  |  |  | 23222035 | 109.0453 | PE | EJ | 13-015 | PR |  |  |
| 23222035a |  | Data Entry / Paperwork - Single Channel Shunt Chassis FY14 |  | 24d | 2013-09-03 A | 2013-09-23 A | 23222030a FS-44d, 23222035 | 100% |  | 2013-10-01 | 2013-11-01 |  |  | 8/5 M-F w/JLAB Holidays ReBaseline | COMP SCIENT [1.09 h]; ELEC DES [1.09 h] | 134.78 | 130.61 | 0 | MERZ B | 1 | 1 | H | BILL M | 10-028 | 12-028 | 12-029F |  |  |  |  |  |  |  |  |  |  |  |  | 23222035 | 134.7785 | PE | EJ | 13-015 | PR | 14-001 |  |
| 23222064 |  | Installation - Shunt Resistor Plates Part A FY13 |  | 62d | 2013-09-03 A | 2013-09-23 A | 9-130M FS+228d | 100% |  | 2013-10-01 | 2014-01-08 |  |  | 8/5 M-F w/JLAB Holidays ReBaseline | ELEC TECH [5.71 h] | 268.31 | 260.03 | 0 | MERZ B | 1 | 1 | U | BILL M | 10-028 | 12-028 |  |  |  |  |  |  |  |  |  |  |  |  |  | 23222064 | 260.0334 | PE | EJ | 13-015 | PR |  |  |
| 23222065 |  | Installation - Shunt Resistor Plates Part A FY14 |  | 42d | 2013-09-03 A | 2013-09-23 A | 23222064 | 100% |  | 2013-10-01 | 2013-11-27 |  |  | 8/5 M-F w/JLAB Holidays ReBaseline | ELEC TECH [12 h] | 563.88 | 546.48 | 0 | MERZ B | 1 | 1 | U | BILL M | 10-028 | 12-028 |  |  |  |  |  |  |  |  |  |  |  |  |  | 23222064 | 563.88 | PE | EJ | 13-015 | PR | 14-001 |  |
| 23222067 |  | Update Machine Documentation - Shunt Resistor Plates Part A FY13 |  | 62d | 2013-09-03 A | 2013-09-23 A | 23222064a FS-98d | 100% |  | 2013-10-01 | 2014-01-08 |  |  | 8/5 M-F w/JLAB Holidays ReBaseline | ELEC TECH [4.9 h] | 230.25 | 223.15 | 0 | MERZ B | 1 | 1 | H | BILL M | 10-028 | 12-028 |  |  |  |  |  |  |  |  |  |  |  |  |  | 23222067 | 223.146 | PE | EJ | 13-015 | PR |  |  |
| 23222068 |  | Update Machine Documentation - Shunt Resistor Plates Part A FY14 |  | 42d | 2013-09-03 A | 2013-09-23 A | 23222067 | 100% |  | 2013-10-01 | 2013-11-27 |  |  | 8/5 M-F w/JLAB Holidays ReBaseline | ELEC TECH [10.28 h] | 483.06 | 468.15 | 0 | MERZ B | 1 | 1 | H | BILL M | 10-028 | 12-028 |  |  |  |  |  |  |  |  |  |  |  |  |  | 23222067 | 483.0572 | PE | EJ | 13-015 | PR | 14-001 |  |
| 23222080A |  | Procurement (Parts) - Track Regulator and 30/80 Part A - Procurement |  | 62d | 2013-09-03 A | 2013-10-21 A | 23222075Aa FS-99d | 100% |  | 2013-10-01 | 2014-01-08 |  |  | 8/5 M-F w/JLAB Holidays ReBaseline | SUPPLIES & MATERIALS; PROCUREMENT<$50K 60 | 12 |  | 6 | MERZ B | 1 | 1 | D | BILL M | 10-028 | 12-028 |  |  | 0 | 12 | 1200 | 100 |  |  |  |  |  |  |  | 23222080A | 6 | EJ | EJ | 13-015 | PR |  | OB |
| 23222080Ab |  | Procurement (Parts) - Track Regulator and 30/80 Part A Expenses FY13 |  | 20d | 2013-09-03 A | 2013-11-27 | 23222075Aa FS-120d | 50% | 19d | 2013-09-03 | 2013-09-30 | 190d | 46d | 8/5 M-F w/JLAB Holidays ReBaseline | SUPPLIES & MATERIALS | 286.53 |  | 0 | MERZ B | 1 | 1 | D | BILL M | 10-028 | 12-028 |  |  |  |  |  |  |  |  |  |  |  |  |  | 23222080A | 143.265 | EJ | EJ | 13-015 | PR |  |  |

Notes:
- 13222020: Steps: Chassis Parts (done); Misc Parts (done); Boards (done); Board Components (done)
- 13222050: Steps: Resistors (done); Heat Sinks (done); Cover Screens (done); Hose/Fittings (done); Thermal Switches (done); Misc Parts (done)
- 13222080: Steps: Chassis (done); Boards (done); Connectors (done); Components (done); IOC/Comm (done)

| ID | Activity | Duration | Start | Finish | Predecessors | Complete | Remaining | Planned start | Planned finish | Total float | Free float | Calendar | Resources | Cost | Actual cost | Original Activity ID Rebaseline | MONTHLY EV COST | PRIOR MONTH EV COST | RESP - Responsibility | STRT%COMP for CM EVM | FNSH%COMP for CM EVM | EVMS Reporting Codes | CAM RESPONSIBLE | CR 10-028 | CR 12-028 | BOE Labor | BOE Expenses | CR 13-015 | Post Rebaseline | CR 14-001 | Activities with Steps | CR 12-029 | LOE % Pre Calc | LOE % | LOE Divider | LOE Multiplier |
| --- | --- | --- | --- | --- | --- | --- | --- | --- | --- | --- | --- | --- | --- | --- | --- | --- | --- | --- | --- | --- | --- | --- | --- | --- | --- | --- | --- | --- | --- | --- | --- | --- | --- | --- | --- | --- |
| 23222080Ac | Procurement (Parts) - Track Regulator and 30/80 Part A Expenses FY14 | 42d | 2013-09-03 A | 2013-11-27 | 23222080Ab FS-65d | 50% | 19d | 2013-10-01 | 2013-11-27 | 144d | 0d | 8/5 M-F w/JLAB Holidays ReBaseline | SUPPLIES & MATERIALS | 620.91 |  | 23222080A | 0 | 310.455 | MERZ B | 1 | 1 | D | BILL M | 10-028 | 12-028 | EJ | EJ | 13-015 | PR | 14-001 |  |  |  |  |  |  |
| 23222085A | Assembly and Testing - Track Regulator and 30/80 Part A FY13 | 62d | 2013-09-03 A | 2013-11-27 | 23222080Aa FS-99d | 50% | 19d | 2013-10-01 | 2014-01-08 | 101d | 0d | 8/5 M-F w/JLAB Holidays ReBaseline | ELEC TECH [44.44 h] | 2,088.24 | 1,427.51 | 23222085A | 0 | 1011.8988 | MERZ B | 1 | 1 | S | BILL M | 10-028 | 12-028 | EJ | EJ | 13-015 | PR |  | ST |  |  |  |  |  |
| 23222085Ab | Assembly and Testing - Track Regulator and 30/80 Part A FY14 | 42d | 2013-09-03 A | 2013-11-25 | 23222085A FS-40d | 50% | 17d | 2013-10-01 | 2013-11-27 | 103d | 2d | 8/5 M-F w/JLAB Holidays ReBaseline | ELEC TECH [93.33 h] | 4,385.58 | 3,097.89 | 23222085A | 0 | 2192.78835 | MERZ B | 1 | 1 | S | BILL M | 10-028 | 12-028 | EJ | EJ | 13-015 | PR | 14-001 | ST |  |  |  |  |  |
| 23222170 | Pull and Modify - 12GEV Shunt Shuffle FY13 | 44d | 2013-09-03 A | 2013-12-06 | 9-130M FS+228d | 85% | 24d | 2013-10-01 | 2013-12-03 | 173d | 1d | 8/5 M-F w/JLAB Holidays ReBaseline | ELEC TECH [50.91 h] | 2,392.26 | 1,053.84 | 23222170 | 231.84414 | 1738.83105 | MERZ B | 1 | 1 | U | BILL M | 10-028 | 12-028 | PE | EJ | 13-015 | PR |  |  | 12-029F |  |  |  |  |
| 23222170a | Pull and Modify - 12GEV Shunt Shuffle FY14 | 24d | 2013-09-03 A | 2013-12-06 | 23222170 FS-25d | 85% | 24d | 2013-10-01 | 2013-11-01 | 173d | 20d | 8/5 M-F w/JLAB Holidays ReBaseline | ELEC TECH [61.09 h] | 2,870.62 | 1,264.56 | 23222170 | 287.06191 | 2152.964325 | MERZ B | 1 | 1 | U | BILL M | 10-028 | 12-028 | PE | EJ | 13-015 | PR | 14-001 |  | 12-029F |  |  |  |  |
| 23222175 | Clean and Modify Racks - 12GEV Shunts FY13 | 44d | 2013-09-03 A | 2013-12-06 | 23222170 FS-44d, 23222170a FS-44d | 89% | 24d | 2013-10-01 | 2013-12-03 | 173d | 20d | 8/5 M-F w/JLAB Holidays ReBaseline | ELEC TECH [87.27 h] | 4,100.82 | 1,806.49 | 23222175 | 357.684822 | 3179.42064 | MERZ B | 1 | 1 | U | BILL M | 10-028 | 12-028 | PE | EJ | 13-015 | PR |  |  | 12-029F |  |  |  |  |
| 23222175a | Clean and Modify Racks - 12GEV Shunts FY14 | 24d | 2013-09-03 A | 2013-12-06 | 23222170a FS-44d | 89% | 24d | 2013-10-01 | 2013-11-01 | 173d | 20d | 8/5 M-F w/JLAB Holidays ReBaseline | ELEC TECH [104.72 h] | 4,920.79 | 2,167.7 | 23222175 | 442.871352 | 3936.63424 | MERZ B | 1 | 1 | U | BILL M | 10-028 | 12-028 | PE | EJ | 13-015 | PR | 14-001 |  | 12-029F |  |  |  |  |
| 23222180 | Reinstall Chassis' in Racks - 12GEV Shunts FY13 | 44d | 2013-09-03 A | 2013-10-21 A | 23222170 FS-44d, 23222170a FS-44d, 23222175a FS-44d, 23222175 FS-44d | 100% |  | 2013-10-01 | 2013-12-03 |  |  | 8/5 M-F w/JLAB Holidays ReBaseline | ELEC TECH [14.55 h] | 683.7 | 678.77 | 23222180 | 397.5642 | 265.0428 | MERZ B | 1 | 1 | U | BILL M | 10-028 | 12-028 | PE | EJ | 13-015 | PR |  |  | 12-029F |  |  |  |  |
| 23222180a | Reinstall Chassis' in Racks - 12GEV Shunts FY14 | 24d | 2013-09-03 A | 2013-10-21 A | 23222180 FS-25d, 23222170a FS-44d, 23222175a FS-44d | 100% |  | 2013-10-01 | 2013-11-01 |  |  | 8/5 M-F w/JLAB Holidays ReBaseline | ELEC TECH [17.46 h] | 820.45 | 812.89 | 23222180 | 492.26724 | 328.17816 | MERZ B | 1 | 1 | U | BILL M | 10-028 | 12-028 | PE | EJ | 13-015 | PR | 14-001 |  | 12-029F |  |  |  |  |
| 23222185 | New Screens for 12 GEV Shunts FY13 | 44d | 2013-09-03 A | 2013-12-06 | 9-130M FS+228d | 50% | 24d | 2013-10-01 | 2013-12-03 | 173d | 1d | 8/5 M-F w/JLAB Holidays ReBaseline | COMP SCIENT [18.18 h] | 1,270.24 | 559.53 | 23222185 | 0 | 615.4839 | MERZ B | 1 | 1 | H | BILL M | 10-028 |  | PE | EJ | 13-015 | PR |  |  | 12-029F |  |  |  |  |
| 23222185a | New Screens for 12 GEV Shunts FY14 | 24d | 2013-09-03 A | 2013-12-06 | 23222185 FS-25d | 50% | 24d | 2013-10-01 | 2013-11-01 | 173d | 20d | 8/5 M-F w/JLAB Holidays ReBaseline | COMP SCIENT [21.82 h] | 1,524.56 | 671.56 | 23222185 | 0 | 762.2817 | MERZ B | 1 | 1 | H | BILL M | 10-028 |  | PE | EJ | 13-015 | PR | 14-001 |  | 12-029F |  |  |  |  |
| 23222190 | Reconfiguration and Testing - 12GEV Shunts FY13 | 44d | 2013-09-03 A | 2013-12-06 | 23222180a FS-44d, 23222185a FS-44d, 23222185 FS-44d, 23222180 FS-44d | 20% | 24d | 2013-10-01 | 2013-12-03 | 153d | 20d | 8/5 M-F w/JLAB Holidays ReBaseline | ELEC TECH [72.73 h] | 3,417.58 | 1,505.51 | 23222190 | 0 | 662.42484 | MERZ B | 1 | 1 | U | BILL M | 10-028 | 12-028 | PE | EJ | 13-015 | PR |  |  | 12-029F |  |  |  |  |
| 23222190a | Reconfiguration and Testing - 12GEV Shunts FY14 | 24d | 2013-09-03 A | 2013-12-06 | 23222180a FS-44d, 23222185a FS-44d | 20% | 24d | 2013-10-01 | 2013-11-01 | 153d | 20d | 8/5 M-F w/JLAB Holidays ReBaseline | ELEC TECH [87.28 h] | 4,101.29 | 1,806.7 | 23222190 | 0 | 820.25744 | MERZ B | 1 | 1 | U | BILL M | 10-028 | 12-028 | PE | EJ | 13-015 | PR | 14-001 |  | 12-029F |  |  |  |  |
| 23222195 | Update Machine Documentation - 12GEV Shunts FY13 | 44d | 2013-09-03 A | 2013-12-06 | 23222190a FS-44d, 23222190 FS-44d | 50% | 24d | 2013-10-01 | 2013-12-03 | 133d | 1d | 8/5 M-F w/JLAB Holidays ReBaseline | ELEC DES [18.18 h]; ELEC ENG [9.09 h] | 1,660.65 | 731.54 | 23222195 | 0 | 804.69225 | MERZ B | 1 | 1 | H | BILL M | 10-028 | 12-028 | PE | EJ | 13-015 | PR |  |  | 12-029F |  |  |  |  |
| 23222195a | Update Machine Documentation - 12GEV Shunts FY14 | 24d | 2013-09-03 A | 2013-12-06 | 23222190a FS-44d, 23222195 FS-25d | 50% | 24d | 2013-10-01 | 2013-11-01 | 133d |  | 8/5 M-F w/JLAB Holidays ReBaseline | ELEC DES [21.81 h]; ELEC ENG [10.91 h] | 1,992.54 | 877.74 | 23222195 | 0 | 996.2694705 | MERZ B | 1 | 1 | H | BILL M | 10-028 | 12-028 | PE | EJ | 13-015 | PR | 14-001 |  | 12-029F |  |  |  |  |
| 23222230 | Drafting (Update Machine Drawings) FY13 | 44d | 2013-09-03 A | 2013-12-06 | 23222220a FS-44d, 23222220 FS-44d | 50% | 24d | 2013-10-01 | 2013-12-03 | 133d | 1d | 8/5 M-F w/JLAB Holidays ReBaseline | ELEC DES [36.36 h]; ELEC ENG [3.64 h] | 2,228.84 | 981.84 | 23222230 | 0 | 1080.0181855 | MERZ B | 1 | 1 | H | BILL M | 10-028 | 12-028 | PE | EJ | 13-015 | PR |  |  | 12-029F |  |  |  |  |
| 23222230a | Drafting (Update Machine Drawings) FY14 | 24d | 2013-09-03 A | 2013-12-06 | 23222230 FS-25d, 23222220a FS-44d | 50% | 24d | 2013-10-01 | 2013-11-01 | 133d |  | 8/5 M-F w/JLAB Holidays ReBaseline | ELEC DES [43.64 h]; ELEC ENG [4.36 h] | 2,674.6 | 1,178.21 | 23222230 | 0 | 1337.3018145 | MERZ B | 1 | 1 | H | BILL M | 10-028 | 12-028 | PE | EJ | 13-015 | PR | 14-001 |  | 12-029F |  |  |  |  |
| 23222075Ab | Oversight (Labor) - Track Regulator and 30/80 FY14 | 42d | 2013-10-01 A | 2013-11-27 |  | 55% | 19d | 2013-11-01 | 2014-01-13 | 947d | 1002d | 8/5 M-F w/JLAB Holidays ReBaseline | ELEC ENG [16.97 h] | 1,274.96 | 698.19 | 23222075A | 698.16596036 |  | MERZ B | 1 | 1 | E | BILL M | 10-028 | 12-028 | EJ | EJ | 13-015 | PR | 14-001 |  |  | 45.23809523 | 54.76190476 | 100 | 100 |
| 23222220 | Installation and Testing - 25 Amp Shunt Upgrade FY13 | 24d | 2013-10-01 A | 2013-12-06 | 9-130M FS+228d | 46% | 24d | 2013-11-01 | 2013-12-06 | 153d | 20d | 8/5 M-F w/JLAB Holidays ReBaseline | ELEC TECH [18.18 h]; ELEC ENG [18.18 h] | 2,220.14 | 1,086.45 | 23222220 | 989.73738 |  | MERZ B | 1 | 1 | U | BILL M | 10-028 | 12-028 | PE | EJ | 13-015 | PR |  |  | 12-029F |  |  |  |  |
| 23222220a | Installation and Testing - 25 Amp Shunt Upgrade FY14 | 24d | 2013-10-01 A | 2013-12-06 |  | 46% | 24d | 2013-11-01 | 2013-12-06 | 153d | 20d | 8/5 M-F w/JLAB Holidays ReBaseline | ELEC TECH [21.82 h]; ELEC ENG [21.82 h] | 2,664.66 | 1,303.98 | 23222220 | 1225.742864 |  | MERZ B | 1 | 1 | U | BILL M | 10-028 | 12-028 | PE | EJ | 13-015 | PR | 14-001 |  | 12-029F |  |  |  |  |
| 23222064a | Installation - Shunt Resistor Plates Part B | 36d | 2013-12-02 | 2014-01-31 | 23222064 FS+47d, 23222065 FS+47d |  |  |  |  | 145d | 43d | 8/5 M-F w/JLAB Holidays ReBaseline | ELEC TECH [8.75 h] | 411.16 |  | 23222064 | 0 |  | MERZ B | 1 | 1 | U | BILL M | 10-028 | 12-028 | PE | EJ | 13-015 | PR | 14-001 |  |  |  |  |  |  |
| 23222067a | Update Machine Documentation - Shunt Resistor Plates Part B | 36d | 2013-12-02 | 2014-01-31 | 23222068 FS+47d, 23222067 FS+47d |  |  |  |  | 102d |  | 8/5 M-F w/JLAB Holidays ReBaseline | ELEC TECH [7.49 h] | 351.96 |  | 23222067 | 0 |  | MERZ B | 1 | 1 | H | BILL M | 10-028 | 12-028 | PE | EJ | 13-015 | PR | 14-001 |  |  |  |  |  |  |
| 23222080Aa | Procurement (Parts) - Track Regulator and 30/80 Part B | 37d | 2013-12-02 | 2014-02-03 | 23222080A, 23222080Ac |  |  |  |  | 144d | 43d | 8/5 M-F w/JLAB Holidays ReBaseline | SUPPLIES & MATERIALS | 464.95 |  | 23222080A | 0 |  | MERZ B | 1 | 1 | D | BILL M | 10-028 | 12-028 | EJ | EJ | 13-015 | PR | 14-001 |  |  |  |  |  |  |
| 23222085Aa | Assembly and Testing - Track Regulator and 30/80 Part B | 37d | 2013-12-02 | 2014-02-03 | 23222085A, 23222085Ab |  |  |  |  | 101d | 0d | 8/5 M-F w/JLAB Holidays ReBaseline | ELEC TECH [69.89 h] | 3,284.13 |  | 23222085A | 0 |  | MERZ B | 1 | 1 | S | BILL M | 10-028 | 12-028 | EJ | EJ | 13-015 | PR | 14-001 | ST |  |  |  |  |  |
| 23222095 | Installation and Testing - Track Regulator and 30/80 | 37d | 2013-12-02 | 2014-02-03 | 23222085Aa FS-37d |  |  |  |  | 101d | 0d | 8/5 M-F w/JLAB Holidays ReBaseline | ELEC TECH [68 h]; ELEC ENG [68 h] | 8,304.16 |  | 23222095 | 0 |  | MERZ B | 1 | 1 | S | BILL M | 10-028 | 12-028 | EJ | EJ | 13-015 | PR | 14-001 | ST |  |  |  |  |  |
| 23222100A | Data Entry/Paperwork - Track Regulator and 30/80 | 37d | 2013-12-02 | 2014-02-03 | 23222095 FS-37d |  |  |  |  | 101d | 0d | 8/5 M-F w/JLAB Holidays ReBaseline | ELEC DES [34 h]; ELEC TECH [34 h] | 3,426.18 |  | 23222100A | 0 |  | MERZ B | 1 | 1 | H | BILL M | 10-028 | 12-028 | EJ | EJ | 13-015 | PR | 14-001 |  |  |  |  |  |  |
| 23222142 | Update Machine Documentation - 75 Amp Shunt Upgrade | 37d | 2013-12-02 | 2014-02-03 | 23222100A FS-37d |  |  |  |  | 101d |  | 8/5 M-F w/JLAB Holidays ReBaseline | ELEC DES [6.8 h] | 365.7 |  | 23222142 | 0 |  | MERZ B | 1 | 1 | H | BILL M | 10-028 | 12-028 | PE | EJ | 13-015 | PR | 14-001 |  |  |  |  |  |  |
| 23222070A | Engineering, Drafting and Software - Track Regulator and 30/80 Part A FY13 | 20d | 2013-12-05 | 2014-01-13 | 9-130M FS+228d, 9-140M FS+45d |  |  |  |  | 152d | 0d | 8/5 M-F w/JLAB Holidays ReBaseline | COMP SCIENT [1.62 h]; ELEC ENG [4.85 h]; ELEC DES [3.23 h] | 651.23 |  | 23222070A | 0 |  | MERZ B | 1 | 1 | H | BILL M | 10-028 | 12-028 | EJ | EJ | 13-015 | PR |  |  |  |  |  |  |  |
| 23222075A | Oversight (Labor) - Track Regulator and 30/80 | 42d | 2013-12-18 | 2014-02-26 | 23222070Aa FS-70d |  |  |  |  | 152d | 0d | 8/5 M-F w/JLAB Holidays ReBaseline | ELEC ENG [8.08 h] | 607.05 |  | 23222075A | 0 |  | MERZ B | 1 | 1 | H | BILL M | 10-028 | 12-028 | EJ | EJ | 13-015 | PR |  |  |  |  |  |  |  |
| 23222070Ab | Engineering, Drafting and Software - Track Regulator and 30/80 Part A FY14 | 22d | 2014-01-14 | 2014-02-13 | 23222070A |  |  |  |  | 152d | 0d | 8/5 M-F w/JLAB Holidays ReBaseline | COMP SCIENT [3.39 h]; ELEC ENG [10.18 h]; ELEC DES [6.79 h] | 1,366.9 |  | 23222070A | 0 |  | MERZ B | 1 | 1 | H | BILL M | 10-028 | 12-028 | EJ | EJ | 13-015 | PR | 14-001 |  |  |  |  |  |  |
| 23222070Aa | Engineering, Drafting and Software - Track Regulator and 30/80 Part B | 37d | 2014-02-14 | 2014-04-07 | 23222070A, 23222070Ab |  |  |  |  | 152d | 0d | 8/5 M-F w/JLAB Holidays ReBaseline | COMP SCIENT [2.54 h]; ELEC ENG [7.62 h]; ELEC DES [5.08 h] | 1,023.16 |  | 23222070A | 0 |  | MERZ B | 1 | 1 | H | BILL M | 10-028 | 12-028 | EJ | EJ | 13-015 | PR | 14-001 |  |  |  |  |  |  |
| 23222075Aa | Oversight (Labor) - Track Regulator and 30/80 | 37d | 2014-02-27 | 2014-04-18 | 23222075A |  |  |  |  | 152d | 0d | 8/5 M-F w/JLAB Holidays ReBaseline | ELEC ENG [12.7 h] | 954.15 |  | 23222075A | 0 |  | MERZ B | 1 | 1 | H | BILL M | 10-028 | 12-028 | EJ | EJ | 13-015 | PR | 14-001 |  |  |  |  |  |  |

Notes:
- 23222085A: Steps: Assembly (done); Bench Test
- 23222085Ab: Steps: Assembly (done); Bench Test
- 23222085Aa: Steps: Assembly; Bench Test
- 23222095: Steps: Install; Test

| ID | WBS | Activity | Type | Duration | Start | Finish | Predecessors | Complete | Remaining | Planned start | Planned finish | Total float | Free float | Calendar | Resources | Cost | Actual cost | Calculated Remaining Total Cost | MONTHLY EV COST | RESP - Responsibility | STRT%COMP for CM EVM | FNSH%COMP for CM EVM | CR 08-005 | EVMS Reporting Codes | CAM RESPONSIBLE | CR 08-027 | CR 10-066 | CR 11-042 | CR 12-028 | Remaining Material Cost Based on % Compl | Claimed Material Cost Based on % Complet | Initial Claimed Material Calc | Claimed Material Divider | Advance Purchase Plan > 500K | 12 GEV MAJOR PROCUREMENT CATAGORY | CR 10-028 | Milestone Level | CR 08-016 | CR 08-051 | CR 09-012 | Phil Dev | MARCH!!! | Activities with Steps | OPC Allison | CR 11-059 | Installation | ReBaseline Actuals Adjustment | Original Activity ID Rebaseline | BOE Labor | BOE Expenses | CR 13-015 | Post Rebaseline | CR 14-001 | PRIOR MONTH EV COST | BOE Procurement | Obligated Prior to Rebaseline |
| --- | --- | --- | --- | --- | --- | --- | --- | --- | --- | --- | --- | --- | --- | --- | --- | --- | --- | --- | --- | --- | --- | --- | --- | --- | --- | --- | --- | --- | --- | --- | --- | --- | --- | --- | --- | --- | --- | --- | --- | --- | --- | --- | --- | --- | --- | --- | --- | --- | --- | --- | --- | --- | --- | --- | --- | --- |
|  | 3 | **1.3.2.2.3 TRIMS** |  |  | 2010-04-26 | 2014-03-05 |  |  |  |  |  |  |  |  |  |  |  |  |  |  |  |  |  |  |  |  |  |  |  |  |  |  |  |  |  |  |  |  |  |  |  |  |  |  |  |  |  |  |  |  |  |  |  |  |  |  |
| 13223038 |  | Bid 20 amp Trim PS (20 A Trims) |  | 284d | 2010-04-26 A | 2011-06-15 A | 121223060a, 9-100M FS+124d | 100% |  |  |  |  |  |  | ELEC ENG [100 h] | 6,755.53 | 6,755.53 | 0 | 6627 | MERZ B | 1 | 1 | 08-005 | H | BILL M | 08-027 | 10-066 | 11-042 | 12-028F |  |  |  |  |  |  |  |  |  |  |  |  |  |  |  |  |  |  |  |  |  |  |  |  |  |  |  |
| 13223030 |  | Proc Rack Hardware for 20 amp Trim PS/Wait for Delivery (20 A TRIMS) |  | 422d | 2010-07-26 A | 2012-04-09 A | 121223060a, 9-110M FS-45d | 100% |  |  |  |  |  |  | ELEC ENG [80 h]; PROCUREMENT<$50K 60 | 121,721.52 | 5,503.27 | 0 | 121688.65 | MERZ B | 1 | 1 |  | D | BILL M |  |  | 11-042 | 12-028F | 0 | 116218.25 | 11621825 | 100 | APP | 3223 | 10-028 |  |  |  |  |  |  |  |  |  |  |  |  |  |  |  |  |  |  |  |  |
| 13223045 |  | Monitor Design & Development &Test of First Article (20 A Trims) |  | 158d | 2011-06-01 A | 2012-01-23 A | 13223039M FS-35d | 100% |  |  |  |  |  |  | TRAVEL; ELEC ENG [80 h] | 7,817.55 | 5,549.87 | 0 | 7738.08 | MERZ B | 1 | 1 |  | H | BILL M |  | 10-066 | 11-042 | 12-028F |  |  |  |  |  |  |  |  |  |  |  |  |  |  |  |  |  |  |  |  |  |  |  |  |  |  |  |
| 13223039M |  | Award 20 amp Trim PS (20 A Trims) | milestone | 0d | 2011-06-27 A | 2011-06-27 A | 9-110M FS+60d, 13223038 | 100% |  | 2011-07-15 | 2011-07-15 |  |  |  |  |  |  |  | 0 | MERZ B | 1 | 1 |  | M | BILL M | 08-027 | 10-066 | 11-042 | 12-028F |  |  |  |  |  |  |  | 6 |  |  |  |  |  |  |  |  |  |  |  |  |  |  |  |  |  |  |  |
| 13223051A |  | Vend Fab 20 Amp Trim Power Supplies - Peg Point #1 NRE |  | 122d | 2011-06-27 A | 2011-12-19 A | 9-110M FS+180d | 100% |  |  |  |  |  |  | PROCUREMENT<$50K 60 NO ESCALATION | 50,000 |  | 0 | 50000 | MERZ B | 1 | 1 |  | D | BILL M | 08-027 | 10-066 | 11-042 | 12-028F | 0 | 50000 | 5000000 | 100 | APP | 3223 | 10-028 |  | 08-016 | 08-051 | 09-012 |  |  |  |  |  |  |  |  |  |  |  |  |  |  |  |  |
| 13223051B |  | Vend Fab 20 Amp Trim Power Supplies - Peg Point #2 Approval of 1st Article Test |  | 364d | 2011-06-27 A | 2013-03-11 A | 13223051A FS-47d | 100% |  | 2011-06-27 | 2012-12-10 |  |  |  | PROCUREMENT>$50K 69 NO ESCALATION | 52,000 |  | 0 | 52000 | MERZ B | 1 | 1 |  | D | BILL M | 08-027 | 10-066 | 11-042 | 12-028F | 0 | 52000 | 5200000 | 100 | APP | 3223 | 10-028 |  | 08-016 | 08-051 | 09-012 | MP | XX |  |  |  |  |  |  |  |  |  |  |  |  |  |  |
| 13223051C |  | Vend Fab 20 Amp Trim Power Supplies - Peg Point #3 First Delivery and Acceptance of 30 units |  | 388d | 2011-06-27 A | 2013-05-13 A | 13223051B FS-89d | 100% |  | 2011-06-27 | 2013-01-22 |  |  |  | PROCUREMENT>$50K 69 NO ESCALATION | 150,000 |  | 0 | 150000 | MERZ B | 1 | 1 |  | S | BILL M | 08-027 | 10-066 | 11-042 | 12-028F | 0 | 150000 | 15000000 | 100 | APP | 3223 | 10-028 |  | 08-016 | 08-051 | 09-012 | MP | XX | ST |  |  |  |  |  |  |  |  |  |  |  |  |  |
| 13223051D |  | Vend Fab 20 Amp Trim Power Supplies - Peg Point #4 Second Delivery and Acceptance of 30 units |  | 388d | 2011-06-27 A | 2013-06-17 A | 13223051C FS-146d | 100% |  | 2011-06-27 | 2013-01-22 |  |  |  | PROCUREMENT>$50K 69 NO ESCALATION | 150,000 |  | 0 | 150000 | MERZ B | 1 | 1 |  | S | BILL M | 08-027 | 10-066 | 11-042 | 12-028F | 0 | 150000 | 15000000 | 100 | APP | 3223 | 10-028 |  | 08-016 | 08-051 | 09-012 | MP | XX | ST |  |  |  |  |  |  |  |  |  |  |  |  |  |
| 13223051F |  | Vend Fab 20 Amp Trim Power Supplies - Peg Point #5 Third Delivery and Acceptance of 30 units |  | 287d | 2012-01-03 A | 2013-07-15 A | 13223051D FS-120d | 100% |  | 2012-01-03 | 2013-02-27 |  |  |  | PROCUREMENT>$50K 69 NO ESCALATION; PROCUREMENT<$50K 60 NO ESCALATION | 120,000 |  | 0 | 120000 | MERZ B | 1 | 1 |  | S | BILL M | 08-027 | 10-066 | 11-042 | 12-028F | 0 | 120000 | 12000000 | 100 | APP | 3223 | 10-028 |  | 08-016 | 08-051 | 09-012 | MP |  | ST |  |  |  |  |  |  |  |  |  |  |  |  |  |
| 13223051G |  | Vend Fab 20 Amp Trim Power Supplies - Peg Point #6 Fourth Delivery and Acceptance of 30 units |  | 287d | 2012-01-03 A | 2013-07-15 A | 13223051F FS-115d | 100% |  | 2012-01-03 | 2013-02-27 |  |  |  | PROCUREMENT>$50K 69 NO ESCALATION | 120,000 |  | 0 | 120000 | MERZ B | 1 | 1 |  | S | BILL M | 08-027 | 10-066 | 11-042 | 12-028F | 0 | 120000 | 12000000 | 100 | APP | 3223 | 10-028 |  | 08-016 | 08-051 | 09-012 | MP |  | ST |  |  |  |  |  |  |  |  |  |  |  |  |  |
| 13223051H |  | Vend Fab 20 Amp Trim Power Supplies - Peg Point #7 Fifth Delivery and Acceptance of 30 units |  | 305d | 2012-01-03 A | 2013-08-30 A | 13223051G FS-135d | 100% |  | 2012-01-03 | 2013-03-25 |  |  |  | PROCUREMENT>$50K 69 NO ESCALATION | 120,000 |  | 92280 | 120000 | MERZ B | 1 | 1 |  | S | BILL M | 08-027 | 10-066 | 11-042 | 12-028F | 0 | 120000 | 12000000 | 100 | APP | 3223 | 10-028 |  | 08-016 | 08-051 | 09-012 | MP |  | ST |  |  |  |  |  |  |  |  |  |  |  |  |  |
| 13223051J |  | Vend Fab 20 Amp Trim Power Supplies - Peg Point #8 Sixth Delivery and Acceptance of 30 units |  | 327d | 2012-01-03 A | 2013-08-30 A | 13223051H FS-160d | 100% |  | 2012-01-03 | 2013-04-24 |  |  |  | PROCUREMENT>$50K 69 NO ESCALATION | 120,000 |  | 92280 | 120000 | MERZ B | 1 | 1 |  | S | BILL M | 08-027 | 10-066 | 11-042 | 12-028F | 0 | 120000 | 12000000 | 100 | APP | 3223 | 10-028 |  | 08-016 | 08-051 | 09-012 | MP |  | ST | OPC A |  |  |  |  |  |  |  |  |  |  |  |  |
| 13223051K |  | Vend Fab 20 Amp Trim Power Supplies - Peg Point #9 Seventh Delivery and Acceptance of 30 units |  | 327d | 2012-01-03 A | 2013-08-30 A | 13223051J FS-179d | 100% |  | 2012-01-03 | 2013-04-24 |  |  |  | PROCUREMENT>$50K 69 NO ESCALATION | 120,000 |  | 92280 | 120000 | MERZ B | 1 | 1 |  | S | BILL M | 08-027 | 10-066 | 11-042 | 12-028F | 0 | 120000 | 12000000 | 100 | APP | 3223 | 10-028 |  | 08-016 | 08-051 | 09-012 | MP |  | ST | OPC A |  |  |  |  |  |  |  |  |  |  |  |  |
| 13223051N |  | Vend Fab 20 Amp Trim Power Supplies - Peg Point #10 Eighth Delivery and Acceptance of 30 units |  | 384d | 2012-01-03 A | 2013-08-30 A | 13223051K FS-204d | 100% |  | 2012-01-03 | 2013-07-16 |  |  |  | PROCUREMENT>$50K 69 NO ESCALATION | 120,000 |  | 92280 | 120000 | MERZ B | 1 | 1 |  | S | BILL M | 08-027 | 10-066 | 11-042 | 12-028F | 0 | 120000 | 12000000 | 100 | APP | 3223 | 10-028 |  | 08-016 | 08-051 | 09-012 | MP |  | ST | OPC A |  |  |  |  |  |  |  |  |  |  |  |  |
| 13223051P |  | Vend Fab 20 Amp Trim Power Supplies - Peg Point #11 Final Delivery and Acceptance of 20 units |  | 384d | 2012-01-03 A | 2013-08-30 A | 13223051N FS-242d | 100% |  | 2012-01-03 | 2013-07-16 |  |  |  | PROCUREMENT>$50K 69 NO ESCALATION | 80,000 |  | 61520 | 80000 | MERZ B | 1 | 1 |  | S | BILL M | 08-027 | 10-066 | 11-042 | 12-028F | 0 | 80000 | 8000000 | 100 | APP | 3223 | 10-028 |  | 08-016 | 08-051 | 09-012 | MP |  | ST | OPC A |  |  |  |  |  |  |  |  |  |  |  |  |
| 13223035 |  | Assemble Racks for 20 amp Trim PS (20 A TRIMS) Frozen per CR12-028 |  | 8d | 2012-03-01 A | 2012-03-12 A | 13223030 FS-10d | 100% |  |  |  |  |  |  | SUPPLIES & MATERIALS; ELEC TECH [500 h] | 26,600.34 | 22,065 | 0 | 25920.34 | MERZ B | 1 | 1 |  | H | BILL M |  |  | 11-042 | 12-028F |  |  |  |  |  |  | 10-028 |  |  |  |  |  |  |  |  |  |  |  |  |  |  |  |  |  |  |  |  |
| 13223035A |  | Reverse Entry Per CR12-028 |  | 8d | 2012-03-01 A | 2012-03-12 A | 9-120M | 100% |  |  |  |  |  |  | ELEC TECH [-604.4 h]; SUPPLIES & MATERIALS; TRAVEL | -33,555.96 | -26,672.17 |  |  | MERZ B | 1 | 1 |  | Z | BILL M |  |  | 11-042 | 12-028 |  |  |  |  |  |  | 10-028 |  |  |  |  |  |  |  |  |  |  |  |  |  |  |  |  |  |  |  |  |
| 13223052 |  | Receive , Inspect, Test PS (20 A Trims) P1 Frozen Per CR 12-028 |  | 8d | 2012-03-01 A | 2012-03-12 A | 13223051D FS-70d, 13223050 FS-70d | 100% |  |  |  |  |  |  | ELEC TECH [120 h]; TRAVEL | 7,635.62 | 5,295.6 | 0 | 7635.62 | MERZ B | 1 | 1 |  | H | BILL M | 08-027 | 10-066 | 11-042 | 12-028F |  |  |  |  |  |  |  |  |  |  |  |  |  |  |  |  |  |  |  |  |  |  |  |  |  |  |  |
| 13223036 |  | Assemble Racks for 20 amp Trims Part A |  | 118d | 2012-04-02 A | 2012-09-17 A | 9-120M FS+120d, 13223030 | 100% |  |  |  |  |  |  | ELEC TECH [120 h]; SUPPLIES & MATERIALS | 6,795.6 | 5,295.6 | 0 | 6795.6 | MERZ B | 1 | 1 |  | H | BILL M |  |  | 11-042 | 12-028 |  |  |  |  |  |  | 10-028 |  |  |  |  |  |  |  |  |  |  |  |  |  |  |  |  |  |  |  |  |
| 13223050 |  | Monitor Production and Delvery of PS (20 A Trims) P1 (original Labor and Expenses) |  | 118d | 2012-04-02 A | 2012-09-17 A | 13223045 | 100% |  |  |  |  |  |  | ELEC ENG [20 h]; TRAVEL; ELEC DES [30 h] | 5,194.18 | 2,926.5 | 0 | 5103.78 | MERZ B | 1 | 1 |  | H | BILL M | 08-027 | 10-066 | 11-042 | 12-028F |  |  |  |  | APP | 3223 | 10-028 |  | 08-016 | 08-051 | 09-012 |  |  |  |  |  |  |  |  |  |  |  |  |  |  |  |  |
| 13223110 |  | SRCC 20 Amp PS PS Procurement |  | 173d | 2012-05-01 A | 2013-08-30 A | 9-120M | 100% |  | 2012-05-01 | 2013-01-11 |  |  |  | PROCUREMENT<$50K 60 NO ESCALATION FY13 | 20,000 |  | 15380 | 20000 | MERZ B | 1 | 1 |  | S | BILL M | 08-027 | 10-066 | 11-042 | 12-028 | 0 | 20000 | 2000000 | 100 |  |  |  |  |  |  |  |  | XX | ST | OPC A | 11-059 |  |  |  |  |  |  |  |  |  |  |  |
| 13223010 |  | Relocate and Reuse Trim Hardware for Hall D |  | 177d | 2012-05-14 A | 2013-05-13 A | 2-02M | 100% |  | 2012-05-14 | 2013-01-31 |  |  |  | ELEC ENG [20 h]; SKLLD TRADE [40 h]; SUPPLIES & MATERIALS; ELEC TECH [120 h] | 13,485.04 | 8,201.28 | 0 | 13368.89 | MERZ B | 1 | 1 |  | H | BILL M |  |  |  | 12-028 |  |  |  |  |  |  | 10-028 |  |  |  |  |  | XX |  |  |  |  |  |  |  |  |  |  |  |  |  |  |
| 13223051Q |  | ** Option** Vend Fab 20 Amp Trim Power Supplies - Peg Point #12 Delivery and Acceptance of 10 units |  | 205d | 2012-09-17 A | 2013-08-30 A | 13223051P FS-200d, 9-130M | 100% |  | 2012-09-17 | 2013-07-16 |  |  |  | PROCUREMENT>$50K 69 NO ESCALATION | 40,000 |  | 30760 | 40000 | MERZ B | 1 | 1 |  | S | BILL M | 08-027 | 10-066 | 11-042 | 12-028F | 0 | 40000 | 4000000 | 100 | APP | 3223 | 10-028 |  | 08-016 | 08-051 | 09-012 |  |  | ST | OPC A |  |  |  |  |  |  |  |  |  |  |  |  |
| 13223036A |  | Assemble Racks for 20 amp Trims Part B |  | 90d | 2012-10-01 A | 2013-07-15 A | 9-130M, 13223036 | 100% |  | 2012-10-01 | 2013-02-14 |  |  |  | ELEC TECH [480 h]; SUPPLIES & MATERIALS | 24,991.02 | 21,859.2 | 0 | 24991.02 | MERZ B | 1 | 1 |  | U | BILL M |  |  | 11-042 | 12-028 |  |  |  |  |  |  | 10-028 |  |  |  |  |  | XX |  | OPC A |  |  |  |  |  |  |  |  |  |  |  |  |
| 13223051 |  | Monitor Production and Delvery of PS (20 A Trims) P2 (original Labor and Expenses) |  | 198d | 2012-10-01 A | 2013-08-30 A | 13223050, 9-120M, 13223045 | 100% |  | 2012-10-01 | 2013-07-19 |  |  |  | ELEC ENG [20 h]; ELEC DES [30 h]; TRAVEL | 5,359.82 | 3,019.8 | 2633.26 | 5266.52 | MERZ B | 1 | 1 |  | H | BILL M | 08-027 | 10-066 | 11-042 | 12-028F |  |  |  |  | APP | 3223 | 10-028 |  | 08-016 | 08-051 | 09-012 |  |  |  | OPC A |  |  |  |  |  |  |  |  |  |  |  |  |
| 13223100 |  | SRCC Engineering Design, Planning and Oversight |  | 36d | 2012-11-12 A | 2013-04-08 A | 9-130M | 100% |  | 2012-11-12 | 2013-01-10 |  |  |  | ELEC ENG [120 h] | 8,737.2 | 8,737.2 | 0 | 8737.2 | MERZ B | 1 | 1 |  | H | BILL M | 08-027 | 10-066 | 11-042 | 12-028 |  |  |  |  |  |  |  |  |  |  |  |  | XX |  | OPC A | 11-059 |  |  |  |  |  |  |  |  |  |  |  |
| 13223105 |  | SRCC Drafting |  | 29d | 2012-11-12 A | 2013-08-12 A | 13223100 FS-40d | 100% |  | 2012-11-12 | 2012-12-31 |  |  |  | ELEC ENG [80 h] | 5,824.8 | 5,824.8 | 2912.4 | 5824.8 | MERZ B | 1 | 1 |  | H | BILL M | 08-027 | 10-066 | 11-042 | 12-028 |  |  |  |  |  |  |  |  |  |  |  |  | XX |  | OPC A | 11-059 |  |  |  |  |  |  |  |  |  |  |  |
| 13223112 |  | SRCC Cable & Misc Procurement |  | 60d | 2012-12-03 A | 2012-12-17 A | 13223100 FS-43d, 13223105 FS-59d | 100% |  | 2013-01-02 | 2013-03-28 |  |  |  | PROCUREMENT<$50K 60 | 10,319 |  | 0 | 10319 | MERZ B | 1 | 1 |  | D | BILL M | 08-027 | 10-066 | 11-042 | 12-028 | 0 | 10319 | 1031900 | 100 |  |  |  |  |  |  |  |  |  |  | OPC A | 11-059 |  |  |  |  |  |  |  |  |  |  |  |
| 13223120 |  | SRCC Cable Installation, Termination and Hook-up |  | 42d | 2012-12-03 A | 2013-08-12 A | 13223110 FS-35d, 13223112, 13223115 FS-45d | 100% |  | 2013-04-26 | 2013-06-25 |  |  |  | ELEC TECH [160 h] | 7,286.4 | 7,286.4 | 728.63999999 | 7286.4 | MERZ B | 1 | 1 |  | U | BILL M | 08-027 | 10-066 | 11-042 | 12-028 |  |  |  |  |  |  |  |  |  |  |  |  |  |  | OPC A | 11-059 |  |  |  |  |  |  |  |  |  |  |  |
| 13223115 |  | SRCC PS and Rack installation |  | 20d | 2013-01-07 A | 2013-08-13 A | 13223112, 13223110 FS-25d | 100% |  | 2013-03-08 | 2013-04-04 |  |  |  | ELEC TECH [80 h]; SKLLD TRADE [40 h] | 5,024 | 5,024 | 2512 | 5024 | MERZ B | 1 | 1 |  | H | BILL M | 08-027 | 10-066 | 11-042 | 12-028 |  |  |  |  |  |  |  |  |  |  |  |  |  |  | OPC A | 11-059 |  |  |  |  |  |  |  |  |  |  |  |
| 13223020 |  | Reconfigure 10 Amp Trim System (Arc 10 Hall D) (10 A TRIMS) |  | 33d | 2013-04-01 A | 2013-07-15 A | 9-130M FS+120d, 3A-22M | 100% |  | 2013-05-01 | 2013-06-17 |  |  |  | ELEC ENG [20 h]; ELEC TECH [240 h]; COMP SCIENT [80 h] | 17,802.6 | 17,802.6 | 0 | 17802.6 | MERZ B | 1 | 1 |  | U | BILL M |  |  |  | 12-028 |  |  |  |  |  |  | 10-028 |  |  |  |  |  |  |  | OPC A |  |  |  |  |  |  |  |  |  |  |  |  |
| 13223052A |  | Receive , Inspect, Test PS (20 A Trims) P1 Revised Per CR 12-028 |  | 77d | 2013-04-01 A | 2013-08-30 A | 9-130M FS+43d, 13223051D FS-70d, 13223050 FS-70d, 9-120M FS+144d | 100% |  | 2013-05-01 | 2013-08-19 |  |  |  | TRAVEL; ELEC TECH [160 h]; ELEC ENG [40 h] | 12,538.82 | 10,198.8 | 4889.288 | 12223.22 | MERZ B | 1 | 1 |  | U | BILL M | 08-027 | 10-066 | 11-042 | 12-028 |  |  |  |  |  |  |  |  |  |  |  |  |  |  |  |  |  |  |  |  |  |  |  |  |  |  |  |
| 13223055 |  | Install PS in Racks (20 A Trims) Part A |  | 40d | 2013-06-03 A | 2013-08-30 A | 13223053 FS-125d, 13223052A FS-60d, 13223052 | 100% |  | 2013-08-22 | 2013-10-17 |  |  |  | ELEC TECH [252 h] | 11,594.84 | 11,476.08 | 5560.38 | 11120.76 | MERZ B | 1 | 1 |  | U | BILL M | 08-027 | 10-066 | 11-042 | 12-028 |  |  |  |  |  |  |  |  |  |  |  |  |  |  |  |  | Install |  |  |  |  |  |  |  |  |  |  |
| 13223015 |  | Test Trim Rack Hardware (10 ATRIMS) |  | 65d | 2013-08-12 A | 2013-08-30 A | 13223010, 9-130M FS+120d | 100% |  | 2013-09-03 | 2013-12-04 |  |  |  | ELEC ENG [20 h]; ELEC TECH [40 h] | 3,350.07 | 3,277.8 | 3277.8 | 3277.8 | MERZ B | 1 | 1 |  | H | BILL M |  |  |  | 12-028 |  |  |  |  |  |  | 10-028 |  |  |  |  |  |  |  | OPC A |  |  |  |  |  |  |  |  |  |  |  |  |
| 13223025 |  | Assemble & Test 10 amp Trim System (10 A TRIMS) |  | 39d | 2013-08-30 A | 2013-08-30 A | 13223020 | 100% |  | 2013-09-03 | 2013-10-25 |  |  |  | ELEC TECH [160 h]; ELEC ENG [40 h]; COMP SCIENT [40 h] | 13,107.53 | 12,907.2 | 12907.2 | 12907.2 | MERZ B | 1 | 1 |  | H | BILL M |  |  |  | 12-028 |  |  |  |  |  |  | 10-028 |  |  |  |  |  |  |  | OPC A |  | Install |  |  |  |  |  |  |  |  |  |  |
| 13223053 |  | Receive , Inspect, Test PS (20 A Trims) P2 |  | 64d | 2013-08-30 A | 2013-08-30 A | 13223052A, 13223051Q FS-189d, 13223051 FS-225d, 13223052 | 100% |  | 2013-10-22 | 2014-01-30 |  |  |  | TRAVEL; ELEC TECH [120 h] | 8,053.47 | 5,464.8 | 7879.47 | 7879.47 | MERZ B | 1 | 1 |  | U | BILL M | 08-027 | 10-066 | 11-042 | 12-028 |  |  |  |  |  |  |  |  |  |  |  |  |  |  | OPC A |  |  |  |  |  |  |  |  |  |  |  |  |
| 13223055A |  | Install PS in Racks (20 A Trims) Part B |  | 65d | 2013-08-30 A | 2013-08-30 A | 13223055 | 100% |  | 2013-09-27 | 2014-01-07 |  |  |  | ELEC TECH [240 h] | 11,266.89 | 10,929.6 | 10929.6 | 10929.6 | MERZ B | 1 | 1 |  | U | BILL M | 08-027 | 10-066 | 11-042 | 12-028 |  |  |  |  |  |  |  |  |  |  |  |  |  |  | OPC A |  |  |  |  |  |  |  |  |  |  |  |  |
| 13223060 |  | Integration Testing of PS (20 A Trims) |  | 75d | 2013-08-30 A | 2013-08-30 A | 13223036, 13223055 FS-130d, 13223035, 2-02M, 13223055A FS-130d, 13223036A | 100% |  | 2013-09-03 | 2013-12-18 |  |  |  | ELEC ENG [23.66 h]; ELEC TECH [197.15 h]; COMP SCIENT [118.29 h]; SUPPLIES & MATERIALS | 22,717.21 | 18,709.73 | 22602.62 | 22279.964466 | MERZ B | 1 | 1 |  | H | BILL M | 08-027 | 10-066 | 11-042 | 12-028 |  |  |  |  |  |  |  |  |  |  |  |  |  |  | OPC A |  |  |  |  |  |  |  |  |  |  |  |  |
| 13223125 |  | SRCC System Q.A., Testing and Documentation |  | 20d | 2013-08-30 A | 2013-08-30 A | 13223115, 13223120 | 100% |  | 2013-09-03 | 2013-09-30 |  |  |  | ELEC ENG [40 h]; ELEC TECH [80 h]; COMP SCIENT [40 h] | 9,264 | 9,264 | 9264 | 9264 | MERZ B | 1 | 1 |  | H | BILL M | 08-027 | 10-066 | 11-042 | 12-028 |  |  |  |  |  |  |  |  |  |  |  |  |  |  | OPC A | 11-059 |  |  |  |  |  |  |  |  |  |  |  |
| 13223130 |  | Re-Baseline Actuals Adjustment |  | 1d | 2013-08-30 A | 2013-08-30 A |  | 100% |  | 2013-09-03 | 2013-09-03 |  |  |  | PROCUREMENT>$50K 69 NO ESCALATION | -235,014.13 |  |  |  |  |  |  |  |  |  |  |  |  |  |  |  |  | 100 |  |  |  |  |  |  |  |  |  |  |  |  |  | ADJ |  |  |  |  |  |  |  |  |  |
| 23223025 |  | Assemble & Test 10 amp Trim System (10 A TRIMS) FY13 |  | 39d | 2013-09-03 A | 2013-11-27 | 9-130M FS+228d | 10% | 19d | 2013-10-01 | 2013-11-22 | 74d | 1d | 8/5 M-F w/JLAB Holidays ReBaseline | ELEC TECH [82.05 h]; ELEC ENG [20.51 h]; COMP SCIENT [20.51 h] | 6,830.13 | 3,394.49 |  | 661.9242338 | MERZ B | 1 | 1 |  | U | BILL M |  |  |  | 12-028 |  |  |  |  |  |  | 10-028 |  |  |  |  |  |  |  |  |  |  |  | 23223025 | EJ | EJ | 13-015 | PR |  |  |  |  |
| 23223025a |  | Assemble & Test 10 amp Trim System (10 A TRIMS) FY14 |  | 19d | 2013-09-03 A | 2013-11-27 | 23223025 FS-20d | 10% | 19d | 2013-10-01 | 2013-10-25 | 74d | 61d | 8/5 M-F w/JLAB Holidays ReBaseline | ELEC TECH [77.95 h]; ELEC ENG [19.49 h]; COMP SCIENT [19.49 h] | 6,488.27 | 3,224.59 |  | 648.8280597 | MERZ B | 1 | 1 |  | U | BILL M |  |  |  | 12-028 |  |  |  |  |  |  | 10-028 |  |  |  |  |  |  |  |  |  |  |  | 23223025 | EJ | EJ | 13-015 | PR | 14-001 |  |  |  |
| 23223051H |  | Vend Fab 20 Amp Trim Power Supplies - Peg Point #7 Fifth Delivery and Acceptance of 30 units |  | 20d | 2013-09-03 A | 2013-09-23 A | 9-130M FS+228d | 100% |  | 2013-10-01 | 2013-10-28 |  |  | 8/5 M-F w/JLAB Holidays ReBaseline | PROCUREMENT>$50K 69 NO ESCALATION | 77,161.74 |  |  | 0 | MERZ B | 1 | 1 |  | D | BILL M | 08-027 | 10-066 | 11-042 | 12-028F | 0 | 77161.74 | 7716174 | 100 | APP | 3223 | 10-028 |  | 08-016 | 08-051 | 09-012 |  |  |  |  |  |  |  | 23223051H |  |  | 13-015 | PR |  | 77161.74 | OB | OB |
| 23223051J |  | Vend Fab 20 Amp Trim Power Supplies - Peg Point #8 Sixth Delivery and Acceptance of 30 units |  | 43d | 2013-09-03 A | 2013-12-05 | 23223051H FS-20d | 40% | 23d | 2013-10-01 | 2013-12-02 | 110d | 20d | 8/5 M-F w/JLAB Holidays ReBaseline | PROCUREMENT>$50K 69 NO ESCALATION | 77,161.74 |  |  | 0 | MERZ B | 1 | 1 |  | D | BILL M | 08-027 | 10-066 | 11-042 | 12-028F | 46297.044 | 30864.696 | 3086469.6 | 100 | APP | 3223 | 10-028 |  | 08-016 | 08-051 | 09-012 |  |  |  |  |  |  |  | 23223051J |  |  | 13-015 | PR |  | 30864.696 | OB | OB |
| 23223051K |  | Vend Fab 20 Amp Trim Power Supplies - Peg Point #9 Seventh Delivery and Acceptance of 30 units |  | 62d | 2013-09-03 A | 2014-01-13 | 23223051J FS-43d |  | 42d | 2013-10-01 | 2014-01-08 | 90d | 20d | 8/5 M-F w/JLAB Holidays ReBaseline | PROCUREMENT>$50K 69 NO ESCALATION | 77,161.74 |  |  | 0 | MERZ B | 1 | 1 |  | D | BILL M | 08-027 | 10-066 | 11-042 | 12-028F | 77161.74 | 0 | 0 | 100 | APP | 3223 | 10-028 |  | 08-016 | 08-051 | 09-012 |  |  |  |  |  |  |  | 23223051K |  |  | 13-015 | PR |  |  | OB | OB |
| 23223051N |  | Vend Fab 20 Amp Trim Power Supplies - Peg Point #10 Eighth Delivery and Acceptance of 30 units |  | 62d | 2013-09-03 A | 2014-01-13 | 23223051K FS-62d |  | 42d | 2013-10-01 | 2014-01-08 | 70d | 20d | 8/5 M-F w/JLAB Holidays ReBaseline | PROCUREMENT>$50K 69 NO ESCALATION | 77,161.74 |  |  | 0 | MERZ B | 1 | 1 |  | D | BILL M | 08-027 | 10-066 | 11-042 | 12-028F | 77161.74 | 0 | 0 | 100 | APP | 3223 | 10-028 |  | 08-016 | 08-051 | 09-012 |  |  |  |  |  |  |  | 23223051N |  |  | 13-015 | PR |  |  | OB | OB |
| 23223051P |  | Vend Fab 20 Amp Trim Power Supplies - Peg Point #11 Final Delivery and Acceptance of 20 units |  | 77d | 2013-09-03 A | 2014-02-04 | 23223051N FS-62d |  | 57d | 2013-10-01 | 2014-01-30 | 50d | 20d | 8/5 M-F w/JLAB Holidays ReBaseline | PROCUREMENT>$50K 69 NO ESCALATION | 51,441.16 |  |  | 0 | MERZ B | 1 | 1 |  | D | BILL M | 08-027 | 10-066 | 11-042 | 12-028F | 51441.16 | 0 | 0 | 100 | APP | 3223 | 10-028 |  | 08-016 | 08-051 | 09-012 |  |  |  |  |  |  |  | 23223051P |  |  | 13-015 | PR |  |  | OB | OB |
| 23223051Q |  | ** Option** Vend Fab 20 Amp Trim Power Supplies - Peg Point #12 Delivery and Acceptance of 10 units |  | 98d | 2013-09-03 A | 2014-03-05 | 23223051P FS-77d |  | 78d | 2013-10-01 | 2014-02-28 | 30d | 17d | 8/5 M-F w/JLAB Holidays ReBaseline | PROCUREMENT>$50K 69 NO ESCALATION | 30,776 |  |  | 0 | MERZ B | 1 | 1 |  | D | BILL M | 08-027 | 10-066 | 11-042 | 12-028F | 30776 | 0 | 0 | 100 | APP | 3223 | 10-028 |  | 08-016 | 08-051 | 09-012 |  |  |  |  |  |  |  | 23223051Q |  |  | 13-015 | PR |  |  | OB | OB |
| 23223052A |  | Receive , Inspect, Test PS (20 A Trims) P1 FY13 |  | 21d | 2013-09-03 A | 2013-09-30 A | 9-130M FS+228d | 100% |  | 2013-10-01 | 2013-10-29 |  |  | 8/5 M-F w/JLAB Holidays ReBaseline | ELEC TECH [9.32 h]; ELEC ENG [2.33 h]; TRAVEL | 749.32 | 594.1 |  | 0 | MERZ B | 1 | 1 |  | U | BILL M | 08-027 | 10-066 | 11-042 | 12-028 |  |  |  |  |  |  |  |  |  |  |  |  |  |  |  |  |  |  | 23223052A | EJ | EJ | 13-015 | PR |  | 730.40049 |  |  |
| 23223052Aa |  | Receive , Inspect, Test PS (20 A Trims) P1 FY14 |  | 1d | 2013-09-03 A | 2013-09-30 A | 23223052A | 100% |  | 2013-10-01 | 2013-10-01 |  |  | 8/5 M-F w/JLAB Holidays ReBaseline | ELEC TECH [0.46 h]; ELEC ENG [0.12 h]; TRAVEL | 37.56 | 29.58 |  | 0 | MERZ B | 1 | 1 |  | U | BILL M | 08-027 | 10-066 | 11-042 | 12-028 |  |  |  |  |  |  |  |  |  |  |  |  |  |  |  |  |  |  | 23223052A | EJ | EJ | 13-015 | PR | 14-001 | 37.558974 |  |  |
| 23223053 |  | Receive , Inspect, Test PS (20 A Trims) P2 Procurement |  | 62d | 2013-09-03 A | 2013-11-27 | 23223052A FS-21d |  | 19d | 2013-10-01 | 2014-01-08 | 95d | 20d | 8/5 M-F w/JLAB Holidays ReBaseline | TRAVEL; ELEC TECH; PROCUREMENT<$50K 60 | 1,155.03 |  |  | 0 | MERZ B | 1 | 1 |  | U | BILL M | 08-027 | 10-066 | 11-042 | 12-028 | 1155.03 | 0 | 0 | 100 |  |  |  |  |  |  |  |  |  |  |  |  |  |  | 23223053 | EJ | EJ | 13-015 | PR |  |  |  | OB |
| 23223054 |  | Receive , Inspect, Test PS (20 A Trims) P2 Labor/Expenses FY13 |  | 20d | 2013-09-03 A | 2014-01-08 | 23223052Aa FS-25d |  | 39d | 2013-09-03 | 2013-09-30 | 101d | 26d | 8/5 M-F w/JLAB Holidays ReBaseline | TRAVEL; ELEC TECH [27.91 h] | 1,832.57 | 677.86 |  | 0 | MERZ B | 1 | 1 |  | U | BILL M | 08-027 | 10-066 | 11-042 | 12-028 |  |  |  |  |  |  |  |  |  |  |  |  |  |  |  |  |  |  | 23223053 | EJ | EJ | 13-015 | PR |  |  |  |  |
| 23223054a |  | Receive , Inspect, Test PS (20 A Trims) P2 Labor/Expenses FY14 |  | 42d | 2013-09-03 A | 2014-01-08 | 23223052Aa FS-50d, 23223054 FS-65d |  | 39d | 2013-10-01 | 2013-11-27 | 75d | 0d | 8/5 M-F w/JLAB Holidays ReBaseline | TRAVEL; ELEC TECH [58.6 h] | 3,970.48 | 1,423.24 |  | 0 | MERZ B | 1 | 1 |  | U | BILL M | 08-027 | 10-066 | 11-042 | 12-028 |  |  |  |  |  |  |  |  |  |  |  |  |  |  |  |  |  |  | 23223053 | EJ | EJ | 13-015 | PR | 14-001 |  |  |  |
| 23223055 |  | Install PS in Racks (20 A Trims) Part A FY13 |  | 31d | 2013-09-03 A | 2013-09-23 A | 23223052A FS-21d, 23223053a FS-101d | 100% |  | 2013-10-01 | 2013-11-12 |  |  | 8/5 M-F w/JLAB Holidays ReBaseline | ELEC TECH [40.65 h] | 1,910.14 | 1,851.2 |  | 0 | MERZ B | 1 | 1 |  | U | BILL M | 08-027 | 10-066 | 11-042 | 12-028 |  |  |  |  |  |  |  |  |  |  |  |  |  |  |  |  |  |  | 23223055 | EJ | EJ | 13-015 | PR |  | 1851.201 |  |  |
| 23223055b |  | Install PS in Racks (20 A Trims) Part A FY14 |  | 11d | 2013-09-03 A | 2013-09-23 A | 23223052Aa FS-21d, 23223055 | 100% |  | 2013-10-01 | 2013-10-15 |  |  | 8/5 M-F w/JLAB Holidays ReBaseline | ELEC TECH [22.35 h] | 1,050.23 | 1,017.82 |  | 0 | MERZ B | 1 | 1 |  | U | BILL M | 08-027 | 10-066 | 11-042 | 12-028 |  |  |  |  |  |  |  |  |  |  |  |  |  |  |  |  |  |  | 23223055 | EJ | EJ | 13-015 | PR | 14-001 | 1050.2265 |  |  |
| 23223110 |  | SRCC 20 Amp PS PS Procurement |  | 67d | 2013-09-03 A | 2013-12-06 | 9-130M FS+228d |  | 24d | 2013-10-01 | 2014-01-15 | 158d | 43d | 8/5 M-F w/JLAB Holidays ReBaseline | PROCUREMENT<$50K 60 NO ESCALATION FY14 | 15,380.25 |  |  | 0 | MERZ B | 1 | 1 |  | D | BILL M | 08-027 | 10-066 | 11-042 | 12-028 | 15380.25 | 0 | 0 | 100 |  |  |  |  |  |  |  |  |  |  |  | 11-059 |  |  | 23223110 |  |  | 13-015 | PR |  |  | OB | OB |
| 23223015 |  | Test Trim Rack Hardware (10 ATRIMS) FY13 |  | 39d | 2013-09-23 A | 2013-11-27 | 9-130M FS+228d | 50% | 19d | 2013-10-01 | 2013-11-22 | 74d | 1d | 8/5 M-F w/JLAB Holidays ReBaseline | ELEC TECH [18.46 h]; ELEC ENG [9.23 h] | 1,560.89 | 363.05 |  | 756.35235 | MERZ B | 1 | 1 |  | U | BILL M |  |  |  | 12-028 |  |  |  |  |  |  | 10-028 |  |  |  |  |  |  |  |  |  |  |  | 23223015 | EJ | EJ | 13-015 | PR |  |  |  |  |
| 23223015a |  | Test Trim Rack Hardware (10 ATRIMS) FY14 |  | 19d | 2013-09-23 A | 2013-11-27 | 23223015 FS-20d | 50% | 19d | 2013-09-23 | 2013-10-17 | 74d | 61d | 8/5 M-F w/JLAB Holidays ReBaseline | ELEC TECH [17.54 h]; ELEC ENG [8.77 h] | 1,468.63 | 344.96 |  | 741.54735 | MERZ B | 1 | 1 |  | U | BILL M |  |  |  | 12-028 |  |  |  |  |  |  | 10-028 |  |  |  |  |  |  |  |  |  |  |  | 23223015 | EJ | EJ | 13-015 | PR | 14-001 |  |  |  |
| 23223060 |  | Integration Testing of PS (20 A Trims) Part A |  | 62d | 2013-10-01 A | 2014-01-09 | 23223055b FS-10d, 23223055 FS-10d, 23223055A FS-130d | 15% | 40d | 2013-11-01 | 2014-02-11 | 37d | 0d | 8/5 M-F w/JLAB Holidays ReBaseline | ELEC TECH [98.37 h]; COMP SCIENT [59.02 h]; SUPPLIES & MATERIALS; ELEC ENG [11.81 h] | 11,471.71 | 3,516.96 |  | 1720.75715835 | MERZ B | 1 | 1 |  | U | BILL M | 08-027 | 10-066 | 11-042 | 12-028 |  |  |  |  |  |  |  |  |  |  |  |  |  |  |  |  |  |  | 23223060 | EJ | EJ | 13-015 | PR | 14-001 |  |  |  |
| 23223125 |  | SRCC System Q.A., Testing and Documentation Part A FY13 |  | 42d | 2013-11-01 | 2014-01-13 | 23223110 FS-67d |  |  |  |  | 115d | 0d | 8/5 M-F w/JLAB Holidays ReBaseline | ELEC TECH [23.88 h]; COMP SCIENT [11.94 h]; ELEC ENG [11.94 h] | 2,853.42 |  |  | 0 | MERZ B | 1 | 1 |  | S | BILL M | 08-027 | 10-066 | 11-042 | 12-028 |  |  |  |  |  |  |  |  |  |  |  |  |  | ST |  | 11-059 |  |  | 23223125 | PE | EJ | 13-015 | PR |  |  |  |  |
| 23223125b |  | SRCC System Q.A., Testing and Documentation Part A FY14 |  | 42d | 2013-11-01 | 2014-01-13 | 23223125 FS-45d |  |  |  |  | 115d | 0d | 8/5 M-F w/JLAB Holidays ReBaseline | ELEC TECH [50.15 h]; COMP SCIENT [25.07 h]; ELEC ENG [25.07 h] | 5,992.42 |  |  | 0 | MERZ B | 1 | 1 |  | S | BILL M | 08-027 | 10-066 | 11-042 | 12-028 |  |  |  |  |  |  |  |  |  |  |  |  |  | ST |  | 11-059 |  |  | 23223125 | PE | EJ | 13-015 | PR | 14-001 |  |  |  |
| 23223055A |  | Install PS in Racks (20 A Trims) Part B |  | 36d | 2013-12-20 | 2014-02-20 | 23223053a FS-30d, 23223055 FS-30d, 23223055b FS-30d |  |  |  |  | 98d | 61d | 8/5 M-F w/JLAB Holidays ReBaseline | ELEC TECH [204 h] | 9,585.96 |  |  | 0 | MERZ B | 1 | 1 |  | U | BILL M | 08-027 | 10-066 | 11-042 | 12-028 |  |  |  |  |  |  |  |  |  |  |  |  |  |  |  |  |  |  | 23223055A | EJ | EJ | 13-015 | PR | 14-001 |  |  |  |
| 23223053a |  | Receive , Inspect, Test PS (20 A Trims) P3 |  | 24d | 2014-01-09 | 2014-02-12 | 23223053, 23223054a |  |  |  |  | 75d | 0d | 8/5 M-F w/JLAB Holidays ReBaseline | TRAVEL; ELEC TECH [20.52 h] | 1,555.28 |  |  | 0 | MERZ B | 1 | 1 |  | U | BILL M | 08-027 | 10-066 | 11-042 | 12-028 |  |  |  |  |  |  |  |  |  |  |  |  |  |  |  |  |  |  | 23223053 | EJ | EJ | 13-015 | PR | 14-001 |  |  |  |
| 23223060a |  | Integration Testing of PS (20 A Trims) Part B |  | 16d | 2014-01-10 | 2014-02-03 | 23223060 |  |  |  |  | 37d | 24d | 8/5 M-F w/JLAB Holidays ReBaseline | ELEC TECH [75.46 h]; COMP SCIENT [45.28 h]; SUPPLIES & MATERIALS; ELEC ENG [9.06 h] | 8,799.71 |  |  | 0 | MERZ B | 1 | 1 |  | U | BILL M | 08-027 | 10-066 | 11-042 | 12-028 |  |  |  |  |  |  |  |  |  |  |  |  |  |  |  |  |  |  | 23223060 | EJ | EJ | 13-015 | PR | 14-001 |  |  |  |
| 23223125a |  | SRCC System Q.A., Testing and Documentation Part B |  | 5d | 2014-01-14 | 2014-01-21 | 23223125, 23223110 FS-67d, 23223125b |  |  |  |  | 115d | 53d | 8/5 M-F w/JLAB Holidays ReBaseline | ELEC TECH [5.08 h]; COMP SCIENT [2.54 h]; ELEC ENG [2.54 h] | 606.41 |  |  | 0 | MERZ B | 1 | 1 |  | S | BILL M | 08-027 | 10-066 | 11-042 | 12-028 |  |  |  |  |  |  |  |  |  |  |  |  |  | ST |  | 11-059 |  |  | 23223125 | PE | EJ | 13-015 | PR | 14-001 |  |  |  |

Notes:
- 13223051C: Steps: Second 10 Units delivered (done); Third 10 Units delivered (done); Material Batch 1 (done); Material Batch 2 (done); Balance of Materials (done); First 10 Units delivered (done)
- 13223051D: Steps: Second 10 Units delivered (done); Material Batch 2 (done); Third 10 Units delivered (done); Balance of Materials (done); First 10 Units delivered (done); Material Batch 1 (done)
- 13223051F: Steps: Second 10 Units delivered (done); Material Batch 2 (done); Third 10 Units delivered (done); Balance of Materials (done); First 10 Units delivered (done); Material Batch 1 (done)
- 13223051G: Steps: Second 10 Units delivered (done); Material Batch 2 (done); Third 10 Units delivered (done); Balance of Materials (done); First 10 Units delivered (done); Material Batch 1 (done)
- 13223051H: Steps: Second 10 Units delivered (done); Material Batch 2 (done); Third 10 Units delivered (done); Balance of Materials (done); First 10 Units delivered (done); Material Batch 1 (done)
- 13223051J: Steps: Second 10 Units delivered (done); Material Batch 2 (done); Third 10 Units delivered (done); Balance of Materials (done); First 10 Units delivered (done); Material Batch 1 (done)
- 13223051K: Steps: Second 10 Units delivered (done); Material Batch 2 (done); Third 10 Units delivered (done); Balance of Materials (done); First 10 Units delivered (done); Material Batch 1 (done)
- 13223051N: Steps: Second 10 Units delivered (done); Material Batch 2 (done); Third 10 Units delivered (done); Balance of Materials (done); First 10 Units delivered (done); Material Batch 1 (done)
- 13223051P: Steps: Second 10 Units delivered (done); Material Batch 2 (done); Balance of Materials (done); First 10 Units delivered (done); Material Batch 1 (done)
- 13223110: Steps: Material Batch 1 (done); Material Batch 2 (done); Balance of Materials (done); Unit Deliveries (done)
- 13223051Q: Steps: Material Batch 1 (done); Material Batch 2 (done); Balance of Materials (done); Unit Deliveries (done)
- 23223125: Steps: Arc 7 Complete; Arc 8 Complete; Arc 9 Complete; Arc 10 Complete; Documentation Complete
- 23223125b: Steps: Arc 7 Complete; Arc 8 Complete; Arc 9 Complete; Arc 10 Complete; Documentation Complete
- 23223125a: Steps: Arc 7 Complete; Arc 8 Complete; Arc 9 Complete; Arc 10 Complete; Documentation Complete

| ID | WBS | Activity | Duration | Start | Finish | Predecessors | Complete | Remaining | Planned start | Planned finish | Total float | Free float | Calendar | Resources | Cost | Actual cost | LOE Divider | LOE Multiplier | Calculated Remaining Total Cost | MONTHLY EV COST | RESP - Responsibility | STRT%COMP for CM EVM | FNSH%COMP for CM EVM | EVMS Reporting Codes | CAM RESPONSIBLE | CR 10-028 | CR 12-028 | LOE % Pre Calc | LOE % | Remaining Material Cost Based on % Compl | Claimed Material Cost Based on % Complet | Initial Claimed Material Calc | Claimed Material Divider | Activities with Steps | Installation | CR 08-041 | CR 08-051 | CR 12-029 | CR 11-055 | CR 12-050 | CR 12-001 | CR 12-035 | Specification | CR 08-052 | CR 10-065 | MARCH!!! | CR 10-059 | CR 11-044 | OPC Allison | CR 12-053 | ReBaseline Actuals Adjustment | Original Activity ID Rebaseline | PRIOR MONTH EV COST | BOE Labor | BOE Expenses | CR 13-015 | Post Rebaseline | BOE NOTES | BOE Adder | Obligated Prior to Rebaseline | CR 14-001 |
| --- | --- | --- | --- | --- | --- | --- | --- | --- | --- | --- | --- | --- | --- | --- | --- | --- | --- | --- | --- | --- | --- | --- | --- | --- | --- | --- | --- | --- | --- | --- | --- | --- | --- | --- | --- | --- | --- | --- | --- | --- | --- | --- | --- | --- | --- | --- | --- | --- | --- | --- | --- | --- | --- | --- | --- | --- | --- | --- | --- | --- | --- |
|  | 4 | **1.3.2.2.4 INSTALLATION** |  | 2010-06-11 | 2013-12-09 |  |  |  |  |  |  |  |  |  |  |  |  |  |  |  |  |  |  |  |  |  |  |  |  |  |  |  |  |  |  |  |  |  |  |  |  |  |  |  |  |  |  |  |  |  |  |  |  |  |  |  |  |  |  |  |  |
| 13224000LOE |  | Installation Coordination FY10 | 78d | 2010-06-11 A | 2010-09-30 A | 9-100M FS+170d | 100% |  |  |  |  |  |  | ELEC DES [320 h] | 15,180.8 | 15,180.8 | 100 | 100 | 0 | 15180.8 | MERZ B | 1 | 1 | E | BILL M | 10-028 | 12-028F |  |  |  |  |  |  |  |  |  |  |  |  |  |  |  |  |  |  |  |  |  |  |  |  |  |  |  |  |  |  |  |  |  |  |
| 13224001LOE |  | Installation Coordination FY11 | 248d | 2010-10-01 A | 2011-09-30 A | 13224000LOE | 100% |  |  |  |  |  |  | ELEC DES [457.85 h] | 22,411.76 | 22,411.76 | 100 | 100 | 0 | 22411.7575 | MERZ B | 1 | 1 | E | BILL M | 10-028 | 12-028F | 8.46774193 | 91.53225806 |  |  |  |  |  |  |  |  |  |  |  |  |  |  |  |  |  |  |  |  |  |  |  |  |  |  |  |  |  |  |  |  |
| 13224005 |  | Proc Box PS Load Cable/Hardware (Installtn) | 308d | 2010-11-15 A | 2012-02-20 A | 121224999, 9-110M | 100% |  | 2010-11-15 | 2012-02-17 |  |  |  | ELEC DES [40 h]; PROCUREMENT<$50K 60 | 108,557.08 | 1,976.44 |  |  | 0 | 108538.64 | MERZ B | 1 | 1 | S | BILL M | 10-028 |  |  |  | 0 | 106580.64 | 10658064 | 100 | ST | Install |  |  |  |  |  |  |  |  |  |  |  |  |  |  |  |  |  |  |  |  |  |  |  |  |  |  |
| 13224010 |  | Proc Trim Mag & Shunt Cable (Installtn) | 47d | 2010-11-15 A | 2011-01-31 A | 9-110M, 121224999 | 100% |  |  |  |  |  |  | PROCUREMENT<$50K 60; ELEC DES [40 h] | 52,692.95 | 1,958 |  |  | 0 | 52692.95 | MERZ B | 1 | 1 | S | BILL M | 10-028 |  |  |  | 0 | 50734.95 | 5073495 | 100 | ST | Install | 08-041 | 08-051 |  |  |  |  |  |  |  |  |  |  |  |  |  |  |  |  |  |  |  |  |  |  |  |  |
| 13224015 |  | Proc Trim Sys AC Pwr, Controls & Interlock Cable (Installtn) | 334d | 2010-11-15 A | 2012-03-27 A | 9-110M, 121224999 | 100% |  |  |  |  |  |  | ELEC DES [40 h]; PROCUREMENT<$50K 60 | 54,623.89 | 1,979.86 |  |  | 0 | 54602.03 | MERZ B | 1 | 1 | S | BILL M | 10-028 |  |  |  | 0 | 52644.03 | 5264403 | 100 | ST | Install |  |  |  |  |  |  |  |  |  |  |  |  |  |  |  |  |  |  |  |  |  |  |  |  |  |  |
| 13224020 |  | Proc Box PS Cable Tray, AC Pwr Matrl's (Installtn) | 169d | 2010-11-15 A | 2011-07-25 A | 121224999, 9-110M | 100% |  |  |  |  |  |  | ELEC DES [40 h]; PROCUREMENT<$50K 60 | 71,915.72 | 1,958 |  |  | 0 | 71915.72 | MERZ B | 1 | 1 | S | BILL M | 10-028 |  |  |  | 0 | 69957.72 | 6995772 | 100 | ST | Install |  |  |  |  |  |  |  |  |  |  |  |  |  |  |  |  |  |  |  |  |  |  |  |  |  |  |
| 13224025 |  | Proc DC Pwr Interconnect Hardware (Installtn) | 61d | 2010-11-15 A | 2011-02-21 A | 9-110M, 121224999 | 100% |  | 2010-11-15 | 2011-02-18 |  |  |  | ELEC DES [40 h]; PROCUREMENT<$50K 60 | 85,306.32 | 1,958 |  |  | 0 | 85306.32 | MERZ B | 1 | 1 | S | BILL M | 10-028 |  |  |  | 0 | 83348.32 | 8334832 | 100 | ST | Install |  |  |  |  |  |  |  |  |  |  |  |  |  |  |  |  |  |  |  |  |  |  |  |  |  |  |
| 13224030 |  | Proc LCW Manifolds/Hose for Arc & Septa PS (Installtn) | 168d | 2010-11-15 A | 2011-07-24 A | 121224999, 9-110M | 100% |  | 2010-11-15 | 2011-07-22 |  |  |  | ELEC TECH [20 h]; PROCUREMENT<$50K 60 | 12,193.77 | 855.4 |  |  | 0 | 12193.77 | MERZ B | 1 | 1 | S | BILL M | 10-028 |  |  |  | 0 | 11338.37 | 1133837 | 100 | ST | Install |  |  |  |  |  |  |  |  |  |  |  |  |  |  |  |  |  |  |  |  |  |  |  |  |  |  |
| 13224040A |  | SAB Box Supply Infrastructure Installation Work | 124d | 2011-03-01 A | 2011-08-23 A | 16111030M | 100% |  |  |  |  |  |  | SKLLD TRADE [880 h]; SUPPLIES & MATERIALS; ELEC DES [40 h]; ELEC ENG [40 h] | 36,624.3 | 33,222.8 |  |  | 0 | 36624.3 | MERZ B | 1 | 1 | S | BILL M | 10-028 | 12-028F |  |  |  |  |  |  | ST |  |  |  | 12-029F |  |  |  |  |  |  |  |  |  |  |  |  |  |  |  |  |  |  |  |  |  |  |  |
| 13224040 |  | NAB Box Supply Infrastructure Installation Work | 106d | 2011-04-01 A | 2011-08-30 A | 16111030M | 100% |  |  |  |  |  |  | ELEC ENG [40 h]; ELEC DES [40 h]; SKLLD TRADE [880 h]; SUPPLIES & MATERIALS | 36,624.3 | 33,222.8 |  |  | 0 | 36624.3 | MERZ B | 1 | 1 | S | BILL M | 10-028 |  |  |  |  |  |  |  | ST | Install |  |  | 12-029F | 11-055 | 12-050F |  |  |  |  |  |  |  |  |  |  |  |  |  |  |  |  |  |  |  |  |  |
| 13224045 |  | Pull/Terminate Box PS Load Cable (Installtn) Arc 10/West Arc FY11 (FY12 @ 13224047) | 75d | 2011-05-13 A | 2011-08-29 A | 4A-01M | 100% |  |  |  |  |  |  | ELEC ENG [16.33 h]; ELEC DES [16.33 h]; SKLLD TRADE [555.33 h] | 19,919.8 | 19,919.8 |  |  | 0 | 19919.7975 | MERZ B | 1 | 1 | U | BILL M | 10-028 | 12-028F |  |  |  |  |  |  |  | Install |  |  | 12-029F |  |  | 12-001 | 12-035F |  |  |  |  |  |  |  |  |  |  |  |  |  |  |  |  |  |  |  |
| 13224047 |  | Pull/Terminate Box PS Load Cable (Installtn) Arc 10/West Arc FY12 (FY11 @ 13224045) | 75d | 2011-05-13 A | 2011-08-29 A | 13224045 | 100% |  |  |  |  |  |  | ELEC ENG [3.67 h]; SKLLD TRADE [124.67 h]; ELEC DES [3.67 h] | 4,472.4 | 4,472.4 |  |  | 0 | 4614.5384 | MERZ B | 1 | 1 | U | BILL M | 10-028 | 12-028F |  |  |  |  |  |  |  |  |  |  | 12-029F |  |  | 12-001 | 12-035F |  |  |  |  |  |  |  |  |  |  |  |  |  |  |  |  |  |  |  |
| 13224085 |  | Pull/Terminate Trim Mag & Shunt Cable (Installtn) | 317d | 2011-05-13 A | 2012-08-20 A | 4A-01M | 100% |  |  |  |  |  |  | ELEC ENG [60 h]; ELEC TECH [80 h]; ELEC DES [20 h]; SKLLD TRADE [200 h] | 15,316.79 | 15,316.79 |  |  | 0 | 14987.4 | MERZ B | 1 | 1 | U | BILL M | 10-028 | 12-028F |  |  |  |  |  |  |  | Install | 08-041 |  |  |  |  |  |  | 13224085 | 08-052 |  |  |  |  |  |  |  |  |  |  |  |  |  |  |  |  |  |
| 13224085A |  | Pull/Terminate Trim Mag (Installtn) East Arc , S/R and BSY | 361d | 2011-08-15 A | 2013-08-30 A | 2-02M FS-175d | 100% |  | 2011-08-15 | 2013-01-31 |  |  |  | ELEC TECH [2200 h] | 97,491.63 | 98,274.01 |  |  | 10018.8 | 100188 | MERZ B | 1 | 1 | U | BILL M | 10-028 | 12-028 |  |  |  |  |  |  |  |  |  |  |  |  |  |  |  | 13224085A |  | 10-065 | XX |  |  |  |  |  |  |  |  |  |  |  |  |  |  |  |
| 13224002LOE |  | Installation Coordination FY12 | 247d | 2011-10-03 A | 2012-09-28 A | 13224001LOE | 100% |  |  |  |  |  |  | ELEC DES [456 h] | 23,032.56 | 23,032.56 | 100 | 100 | 0 | 23032.56 | MERZ B | 1 | 1 | E | BILL M | 10-028 | 12-028F | 7.69230769 | 92.3076923 |  |  |  |  |  |  |  |  |  |  |  |  |  |  |  |  |  |  |  |  |  |  |  |  |  |  |  |  |  |  |  |  |
| 13224050 |  | Pull/Terminate Arc & H-D Klixon Cable (Installtn) Frozen Per CR12-028 | 8d | 2012-03-01 A | 2012-03-12 A | 16332030 FS+5d, 9-120M FS+120d | 100% |  |  |  |  |  |  | ELEC ENG [8.5 h]; ELEC TECH [34 h]; SKLLD TRADE [170 h]; ELEC DES [8.5 h] | 8,216.02 | 8,216.02 |  |  | 0 | 8216.015 | MERZ B | 1 | 1 | H | BILL M | 10-028 | 12-028 |  |  |  |  |  |  |  | Install |  |  |  |  |  |  |  |  |  |  |  | 10-059 | 11-044 |  |  |  |  |  |  |  |  |  |  |  |  |  |
| 13224053 |  | Reverse Entry Per CR12-028 | 8d | 2012-03-01 A | 2012-03-12 A |  | 100% |  |  |  |  |  |  | ELEC TECH [-34 h]; SKLLD TRADE [-170 h]; ELEC ENG [-8.5 h]; ELEC DES [-8.5 h] | -8,216.02 | -8,216.02 |  |  |  |  | MERZ B | 1 | 1 | Z | BILL M | 10-028 | 12-028 |  |  |  |  |  |  |  |  |  |  |  |  |  |  |  |  |  |  |  | 10-059 | 11-044 |  |  |  |  |  |  |  |  |  |  |  |  |  |
| 13224080 |  | Install Trim Rack AC Pwr (Installtn) Part A | 201d | 2012-03-02 A | 2013-04-14 A | 13224075 FS-104d | 100% |  | 2012-03-02 | 2012-12-14 |  |  |  | SKLLD TRADE [400 h] | 13,492.86 | 13,580.14 |  |  | 0 | 13380 | MERZ B | 1 | 1 | H | BILL M | 10-028 | 12-028 |  |  |  |  |  |  |  | Install |  |  |  |  |  |  |  | 13224080 |  |  | XX |  |  |  |  |  |  |  |  |  |  |  |  |  |  |  |
| 13224044 |  | Label, Disconnect Pull Back SR Cables | 44d | 2012-05-14 A | 2012-07-16 A | 2-02M | 100% |  |  |  |  |  |  | SKLLD TRADE [120 h]; ELEC TECH [120 h] | 9,309.6 | 9,309.6 |  |  | 0 | 9309.6 | MERZ B | 1 | 1 | H | BILL M | 10-028 | 12-028 |  |  |  |  |  |  |  |  |  |  |  |  |  |  | 12-035F | 13224044 |  |  |  |  |  |  |  |  |  |  |  |  |  |  |  |  |  |  |
| 13224075 |  | Install Trim Racks (Installtn) | 113d | 2012-05-14 A | 2012-10-22 A | 3A-21M, 3A-22M | 100% |  |  |  |  |  |  | SKLLD TRADE [120 h]; ELEC DES [20 h]; ELEC ENG [20 h] | 6,464.51 | 6,464.51 |  |  | 0 | 6435.4 | MERZ B | 1 | 1 | H | BILL M | 10-028 | 12-028 |  |  |  |  |  |  |  | Install |  |  |  |  |  |  |  | 13224075 |  |  |  |  |  |  |  |  |  |  |  |  |  |  |  |  |  |  |
| 13224085B |  | Pull & Terminate Shunt Cable (Remove Old Cable)-Part A | 55d | 2012-06-05 A | 2012-08-20 A | 2-02M | 100% |  |  |  |  |  |  | ELEC TECH [240 h] | 10,591.2 | 10,591.2 |  |  | 0 | 10591.2 | MERZ B | 1 | 1 | U | BILL M | 10-028 | 12-028 |  |  |  |  |  |  |  |  |  |  | 12-029F |  |  |  |  | 13224085B |  |  |  |  |  |  |  |  |  |  |  |  |  |  |  |  |  |  |
| 13224085C |  | Pull & Terminate Shunt Cable (Remove Old Cable)-Part B | 100d | 2012-09-03 A | 2013-07-15 A | 2-02M, 13224085B | 100% |  | 2012-09-04 | 2013-02-01 |  |  |  | ELEC TECH [320 h] | 14,487.07 | 14,532.55 |  |  | 0 | 14572.8 | MERZ B | 1 | 1 | U | BILL M | 10-028 | 12-028 |  |  |  |  |  |  |  |  |  |  |  |  |  |  |  | 13224085C |  |  | XX |  |  |  |  |  |  |  |  |  |  |  |  |  |  |  |
| 13224003LOE |  | Installation Coordination FY13 | 248d | 2012-10-01 A | 2013-08-30 A | 13224002LOE | 100% |  | 2012-10-01 | 2013-09-30 |  |  |  | ELEC ENG [367.74 h] | 26,775.15 | 26,775.15 | 100 | 100 | 4933.6056 | 26775.1494 | MERZ B | 1 | 1 | E | BILL M | 10-028 | 12-028 | 8.06451612 | 91.93548387 |  |  |  |  |  |  |  |  |  |  |  |  |  |  |  |  |  |  |  | OPC A |  |  |  |  |  |  |  |  |  |  |  |  |
| 13224050A |  | Cable Tray Install Hall D Tunnel | 16d | 2012-10-01 A | 2012-10-22 A | 9-130M FS+43d | 100% |  |  |  |  |  |  | SKLLD TRADE [160 h] | 5,523.2 | 5,523.2 |  |  | 0 | 5523.2 | MERZ B | 1 | 1 | H | BILL M | 10-028 | 12-028 |  |  |  |  |  |  |  |  |  |  |  |  |  |  |  | 13224050A |  |  |  | 10-059 | 11-044 |  |  |  |  |  |  |  |  |  |  |  |  |  |
| 13224095 |  | Install Trim Comm/Controls Cable (Installtn) FY12 | 11d | 2012-11-05 A | 2012-11-19 A | 13224075 FS+61d | 100% |  |  |  |  |  |  | ELEC DES [56 h]; ELEC TECH [350 h]; ELEC ENG [28 h] | 20,896.4 | 20,896.4 |  |  | 0 | 20249.74 | MERZ B | 1 | 1 | H | BILL M | 10-028 | 12-028 |  |  |  |  |  |  |  | Install |  |  |  |  |  |  |  | 13224095 |  |  |  |  |  |  | 12-053 |  |  |  |  |  |  |  |  |  |  |  |
| 13224095a |  | Install Trim Comm/Controls Cable (Installtn) FY13 | 73d | 2012-11-19 A | 2012-12-17 A | 13224095 | 100% |  | 2012-11-19 | 2013-03-13 |  |  |  | ELEC DES [24 h]; ELEC TECH [150 h]; ELEC ENG [12 h] | 8,955.6 | 8,955.6 |  |  | 0 | 8955.6 | MERZ B | 1 | 1 | H | BILL M | 10-028 | 12-028 |  |  |  |  |  |  |  |  |  |  |  |  |  |  |  | 13224095a |  |  |  |  |  |  | 12-053 |  |  |  |  |  |  |  |  |  |  |  |
| 13224052 |  | Pull/Terminate Arc & H-D Klixon Cable (Installtn) Revised Per CR12-028 | 40d | 2012-12-03 A | 2013-07-15 A | 9-130M FS+43d | 100% |  | 2013-01-02 | 2013-02-28 |  |  |  | ELEC TECH [80 h]; SKLLD TRADE [160 h] | 9,166.4 | 9,166.4 |  |  | 0 | 9166.4 | MERZ B | 1 | 1 | H | BILL M | 10-028 | 12-028 |  |  |  |  |  |  |  |  |  |  |  |  |  |  |  | 13224052 |  |  | XX | 10-059 | 11-044 |  |  |  |  |  |  |  |  |  |  |  |  |  |
| 13224055 |  | Connect Arc & Hall Mag Load & Klixon Cables (Installtn) | 184d | 2013-01-07 A | 2013-08-30 A | 13224050A, 13224050, 13224040A, 13224040, 13221115 FS-10d, 13221135 FS-110d, 13224047, 13224045A FS-110d | 100% |  | 2013-07-01 | 2014-03-31 |  |  |  | ELEC TECH [55.65 h]; SKLLD TRADE [83.48 h] | 5,528.57 | 5,416.05 |  |  | 7785.6 | 5416.05264 | MERZ B | 1 | 1 | H | BILL M | 10-028 | 12-028 |  |  |  |  |  |  |  | Install |  |  | 12-029F |  |  |  |  | 13224055 |  |  |  |  |  |  |  |  |  |  |  |  |  |  |  |  |  |  |
| 13224045A |  | Pull/Terminate Box PS Load Cable (Installtn) East Arc, S/R,BSY and Extraction | 104d | 2013-01-14 A | 2013-04-15 A | 2-02M, 13224044, 13221115 FS-50d, 9-130M FS+60d | 100% |  | 2013-02-01 | 2013-06-28 |  |  |  | SKLLD TRADE [200 h] | 6,904 | 6,904 |  |  | 0 | 6904 | MERZ B | 1 | 1 | H | BILL M | 10-028 | 12-028 |  |  |  |  |  |  |  |  |  |  | 12-029F |  |  |  | 12-035F | 13224045A |  |  |  |  |  |  |  |  |  |  |  |  |  |  |  |  |  |  |
| 13224100 |  | Update/Install/Test Mag Controls Software (Installtn) | 150d | 2013-03-04 A | 2013-08-30 A | 2-02M, 9-130M | 100% |  | 2013-04-01 | 2013-10-30 |  |  |  | COMP SCIENT [480 h] | 32,652.86 | 32,500.8 |  |  | 16250.4 | 32500.8 | MERZ B | 1 | 1 | H | BILL M |  | 12-028 |  |  |  |  |  |  |  | Install |  |  |  |  |  |  |  | 13224100 |  |  |  |  |  |  |  |  |  |  |  |  |  |  |  |  |  |  |
| 13224090 |  | Pull/terminate/Connect Trim Mag Load Cable - H-D (Installtn) | 45d | 2013-05-03 A | 2013-07-15 A | 121224999, 2-17M, 13224052 FS-83d, 13224050 FS-83d, 121224065 | 100% |  | 2013-06-03 | 2013-08-05 |  |  |  | ELEC DES [20 h]; SKLLD TRADE [200 h]; ELEC ENG [20 h] | 9,402.6 | 9,402.6 |  |  | 0 | 9402.6 | MERZ B | 1 | 1 | H | BILL M | 10-028 | 12-028 |  |  |  |  |  |  |  | Install |  |  |  |  |  |  |  | 13224090 |  |  |  | 10-059 | 11-044 |  |  |  |  |  |  |  |  |  |  |  |  |  |
| 13224080A |  | Install Trim Rack AC Pwr (Installtn) Part B | 35d | 2013-06-01 A | 2013-07-15 A | 13224080 | 100% |  | 2013-07-01 | 2013-08-19 |  |  |  | SKLLD TRADE [400 h] | 13,808 | 13,808 |  |  | 0 | 13808 | MERZ B | 1 | 1 | H | BILL M | 10-028 | 12-028 |  |  |  |  |  |  |  |  |  |  |  |  |  |  |  | 13224080A |  |  |  |  |  |  |  |  |  |  |  |  |  |  |  |  |  |  |
| 13224087 |  | BSY Serv. Bldg Infrastructure Installation- Tray, Power, Water, Controls | 9d | 2013-06-01 A | 2013-08-30 A | 9-130M FS+184d | 100% |  | 2013-07-01 | 2013-07-12 |  |  |  | ELEC ENG [40 h]; SKLLD TRADE [400 h]; ELEC TECH [200 h] | 25,828.4 | 25,828.4 |  |  | 12914.2 | 25828.4 | MERZ B | 1 | 1 | H | BILL M | 10-028 | 12-028 |  |  |  |  |  |  |  |  |  |  |  |  |  |  |  | 13224087 |  |  |  |  |  |  |  |  |  |  |  |  |  |  |  |  |  |  |
| 13224110 |  | Intergation , Inspection, Test Trim PS (Installtn) | 69d | 2013-08-30 A | 2013-08-30 A | 13224080, 13224080A, 13224095a FS-25d, 13224090, 13224085, 13224085A | 100% |  | 2013-09-17 | 2013-12-31 |  |  |  | ELEC TECH [500 h]; ELEC DES [80 h]; SUPPLIES & MATERIALS; ELEC ENG [40 h] | 31,956.67 | 29,852 |  |  | 31143.84 | 31143.84 | MERZ B | 1 | 1 | H | BILL M | 10-028 | 12-028 |  |  |  |  |  |  |  | Install |  |  |  |  |  |  |  | 13224110 |  |  |  |  |  |  |  |  |  |  |  |  |  |  |  |  |  |  |
| 13224115 |  | Re-Baseline Actuals Adjustment | 1d | 2013-08-30 A | 2013-08-30 A |  | 100% |  | 2013-09-03 | 2013-09-03 |  |  |  | PROCUREMENT>$50K 69 NO ESCALATION | 483,126.98 |  |  |  |  | 483126.98 |  |  |  |  |  |  |  |  |  | 0 | 483126.98 | 48312698 | 100 |  |  |  |  |  |  |  |  |  |  |  |  |  |  |  |  |  | ADJ |  |  |  |  |  |  |  |  |  |  |
| 23224003LOE |  | Installation Coordination FY13 | 20d | 2013-09-03 A | 2013-09-30 A | 9-130M FS+228d | 100% |  | 2013-10-01 | 2013-10-28 |  |  | 8/5 M-F w/JLAB Holidays ReBaseline | ELEC ENG [32.25 h] | 2,422.94 | 2,348.12 | 100 | 100 |  | 0 | MERZ B | 1 | 1 | E | BILL M | 10-028 | 12-028 |  |  |  |  |  |  |  |  |  |  |  |  |  |  |  |  |  |  |  |  |  |  |  |  | 23224003LOE | 2348.1225 | EJ | EJ | 13-015 | PR |  |  |  |  |
| 23224045A |  | Pull/Terminate Box PS Load Cable (Installtn) East Arc, S/R,BSY and Extraction - Procurement | 47d | 2013-09-03 A | 2013-10-21 A | 9-130M FS+228d | 100% |  | 2013-10-01 | 2013-12-06 |  |  | 8/5 M-F w/JLAB Holidays ReBaseline | ELEC TECH; SUPPLIES & MATERIALS; SKLLD TRADE; PROCUREMENT<$50K 60 | 73.53 |  |  |  |  | 44.118 | MERZ B | 1 | 1 | U | BILL M | 10-028 | 12-028 |  |  | 0 | 73.53 | 7353 | 100 |  |  |  |  | 12-029F |  |  |  | 12-035F |  |  |  |  |  |  |  |  |  | 23224045A | 29.412 | PE | EJ | 13-015 | PR | BSY tunnel may require additional effort and materials | NO | OB |  |
| 23224045Aa |  | Pull/Terminate Box PS Load Cable (Installtn) East Arc, S/R,BSY and Extraction Labor/Expenses FY13 | 20d | 2013-09-03 A | 2013-11-11 | 9-130M FS+228d | 40% | 7d | 2013-09-03 | 2013-09-30 | 86d | 23d | 8/5 M-F w/JLAB Holidays ReBaseline | ELEC TECH [15.32 h]; SUPPLIES & MATERIALS; SKLLD TRADE [5.11 h] | 1,086.87 | 764.53 |  |  |  | 0 | MERZ B | 1 | 1 | U | BILL M | 10-028 | 12-028 |  |  |  |  |  |  |  |  |  |  | 12-029F |  |  |  | 12-035F |  |  |  |  |  |  |  |  |  | 23224045A | 434.74702 | PE | EJ | 13-015 | PR | BSY tunnel may require additional effort and materials | NO |  |  |
| 23224045Ab |  | Pull/Terminate Box PS Load Cable (Installtn) East Arc, S/R,BSY and Extraction Labor/Expenses FY14 | 27d | 2013-09-03 A | 2013-11-11 | 23224045Aa FS-30d | 40% | 7d | 2013-10-01 | 2013-11-06 | 86d | 40d | 8/5 M-F w/JLAB Holidays ReBaseline | ELEC TECH [20.68 h]; SUPPLIES & MATERIALS; SKLLD TRADE [6.89 h] | 1,513.98 | 1,032.09 |  |  |  | 0 | MERZ B | 1 | 1 | U | BILL M | 10-028 | 12-028 |  |  |  |  |  |  |  |  |  |  | 12-029F |  |  |  | 12-035F |  |  |  |  |  |  |  |  |  | 23224045A | 605.59122 | PE | EJ | 13-015 | PR | BSY tunnel may require additional effort and materials | NO |  | 14-001 |
| 23224055 |  | Connect Arc & Hall Mag Load & Klixon Cables (Installtn) FY13 | 47d | 2013-09-03 A | 2013-11-11 | 23224045A FS-47d, 2813221005 FS-110d, 2813221005a FS-110d | 40% | 7d | 2013-10-01 | 2013-12-06 | 46d | 23d | 8/5 M-F w/JLAB Holidays ReBaseline | SKLLD TRADE [40.85 h]; ELEC TECH [27.24 h] | 2,735.04 | 2,318.36 |  |  |  | 0 | MERZ B | 1 | 1 | U | BILL M | 10-028 | 12-028 |  |  |  |  |  |  |  |  |  |  | 12-029F |  |  |  |  |  |  |  |  |  |  |  |  |  | 23224055 | 1060.243008 | PE | EJ | 13-015 | PR |  |  |  |  |
| 23224055a |  | Connect Arc & Hall Mag Load & Klixon Cables (Installtn) FY14 | 27d | 2013-09-03 A | 2013-11-11 | 23224055 FS-30d, 23224045Aa FS-47d, 23224045Ab FS-47d | 40% | 7d | 2013-10-01 | 2013-11-06 | 46d | 28d | 8/5 M-F w/JLAB Holidays ReBaseline | SKLLD TRADE [55.15 h]; ELEC TECH [36.77 h] | 3,692.24 | 3,129.74 |  |  |  | 0 | MERZ B | 1 | 1 | U | BILL M | 10-028 | 12-028 |  |  |  |  |  |  |  |  |  |  | 12-029F |  |  |  |  |  |  |  |  |  |  |  |  |  | 23224055 | 1476.897024 | PE | EJ | 13-015 | PR |  |  |  | 14-001 |
| 23224085A |  | Pull/Terminate Trim Mag (Installtn) East Arc , S/R and BSY FY13 | 42d | 2013-09-03 A | 2013-09-23 A | 9-130M FS+228d | 100% |  | 2013-10-01 | 2013-11-27 |  |  | 8/5 M-F w/JLAB Holidays ReBaseline | ELEC TECH [45.71 h] | 2,147.91 | 2,081.63 |  |  |  | 0 | MERZ B | 1 | 1 | U | BILL M | 10-028 | 12-028 |  |  |  |  |  |  |  |  |  |  |  |  |  |  |  |  |  | 10-065 |  |  |  |  |  |  | 23224085A | 2081.6334 | PE | EJ | 13-015 | PR | BSY tunnel may require additional effort and materials | NO |  |  |
| 23224085Aa |  | Pull/Terminate Trim Mag (Installtn) East Arc , S/R and BSY FY14 | 15d | 2013-09-03 A | 2013-09-23 A | 23224085A | 100% |  |  |  |  |  | 8/5 M-F w/JLAB Holidays ReBaseline | ELEC TECH [50.29 h] | 2,290.21 | 2,290.21 |  |  |  | 0 | MERZ B | 1 | 1 | U | BILL M | 10-028 | 12-028 |  |  |  |  |  |  |  |  |  |  |  |  |  |  |  |  |  | 10-065 |  |  |  |  |  |  | 23224085A | 2363.1271 | PE | EJ | 13-015 | PR | BSY tunnel may require additional effort and materials | NO |  | 14-001 |
| 23224087 |  | BSY Serv. Bldg Infrastructure Installation- Tray, Power, Water, Controls FY13 | 42d | 2013-09-03 A | 2013-12-04 | 9-130M FS+228d | 39% | 22d | 2013-10-01 | 2013-11-27 | 260d | 8d | 8/5 M-F w/JLAB Holidays ReBaseline | ELEC TECH [47.62 h]; ELEC ENG [9.52 h]; SKLLD TRADE [95.24 h]; SUPPLIES & MATERIALS | 9,916.92 | 2,928.37 |  |  |  | 0 | MERZ B | 1 | 1 | S | BILL M | 10-028 | 12-028 |  |  |  |  |  |  | ST |  |  |  |  |  |  |  |  |  |  |  |  |  |  |  |  |  | 23224087 | 3781.47312845 | EJ | EJ | 13-015 | PR | Extent of upgrades may be greater than planned | NO |  |  |
| 23224087a |  | BSY Serv. Bldg Infrastructure Installation- Tray, Power, Water, Controls FY14 | 22d | 2013-09-03 A | 2013-12-04 | 23224087 FS-30d | 39% | 22d | 2013-10-01 | 2013-10-30 | 260d |  | 8/5 M-F w/JLAB Holidays ReBaseline | ELEC TECH [52.38 h]; ELEC ENG [10.48 h]; SKLLD TRADE [104.76 h]; SUPPLIES & MATERIALS | 11,034 | 3,221.25 |  |  |  | 0 | MERZ B | 1 | 1 | S | BILL M | 10-028 | 12-028 |  |  |  |  |  |  | ST |  |  |  |  |  |  |  |  |  |  |  |  |  |  |  |  |  | 23224087 | 4292.22827603 | EJ | EJ | 13-015 | PR | Extent of upgrades may be greater than planned | NO |  | 14-001 |
| 23224100 |  | Update/Install/Test Mag Controls Software (Installtn) FY13 | 45d | 2013-09-03 A | 2013-12-09 | 9-130M FS+228d | 65% | 25d | 2013-10-01 | 2013-12-04 | 77d | 5d | 8/5 M-F w/JLAB Holidays ReBaseline | COMP SCIENT [93.87 h] | 6,558.7 | 2,824.86 |  |  |  | 0 | MERZ B | 1 | 1 | S | BILL M |  | 12-028 |  |  |  |  |  |  | ST |  |  |  |  |  |  |  |  |  |  |  |  |  |  |  |  |  | 23224100 | 4131.359505 | PE | EJ | 13-015 | PR |  |  |  |  |
| 23224100a |  | Update/Install/Test Mag Controls Software (Installtn) FY14 | 25d | 2013-09-03 A | 2013-12-09 | 23224100 FS-30d | 65% | 25d | 2013-10-01 | 2013-11-04 | 77d | 15d | 8/5 M-F w/JLAB Holidays ReBaseline | COMP SCIENT [117.34 h] | 8,198.55 | 3,531.15 |  |  |  | 0 | MERZ B | 1 | 1 | S | BILL M |  | 12-028 |  |  |  |  |  |  | ST |  |  |  |  |  |  |  |  |  |  |  |  |  |  |  |  |  | 23224100 | 5329.05477 | PE | EJ | 13-015 | PR |  |  |  | 14-001 |

Notes:
- 13224005: Steps: Arc 10 Cable (done); BSY Load Cable (done); Ext PS Load Cable (done); Hall D Load Cable (done); Misc Hardware (done)
- 13224010: Steps: Trim Cable (done); Shunt Cable (done)
- 13224015: Steps: Interlock & Control Cable (done); AC Pwr (Breakers, Material) for Trim Racks (done)
- 13224020: Steps: Core Drill Penetrations (done); AC Power Cable Proc (done); Tray for NAB (done); Tray for SAB (done); Junction Boxes (done); Misc (done)
- 13224025: Steps: NAB/SAB DC Cable to Tunnel (done); Tray, Hangers, Lugs (done); Misc (done)
- 13224030: Steps: NAB Materials (done); SAB Materials (done); Misc For NAB (Valves, Fittings, Etc) (done); Misc For SAB (Valves, Fittings, Etc) (done)
- 13224040A: Steps: Infrastructure Demolition/PS Removal (done); LCW Header Install (done); AC Power Tray Install (done); AC Cable Install (done); DC Tray Install (done); DC Cable Install (done); Controls Install (done); Junction Box Install (done); Tunnel Work (done); PS Install (done)
- 13224040: Steps: Infrastructure Demolition/PS Removal (done); LCW Header Install (done); AC Power Tray Install (done); AC Cable Install (done); DC Tray Install (done); DC Cable Install (done); Controls Install (done); Junction Box Install (done); Tunnel Work (done); PS Install (done)
- 13224045: Entry Criteria: magnets removed, tunnel clear
- 13224047: Entry Criteria: magnets removed, tunnel clear
- 13224085: Entry Criteria: magnets removed for pull, magnets in / place to connect & terminate
- 13224085A: Entry Criteria: magnets removed for pull, magnets in / place to connect & terminate
- 13224050: Entry Criteria: magnets removed, tunnel / clear
- 13224053: Entry Criteria: magnets removed, tunnel / clear
- 13224044: Entry Criteria: magnets removed, tunnel clear
- 13224085B: Entry Criteria: magnets removed for pull, magnets in / place to connect & terminate
- 13224085C: Entry Criteria: magnets removed for pull, magnets in / place to connect & terminate
- 13224050A: Entry Criteria: magnets removed, tunnel / clear
- 13224052: Entry Criteria: magnets removed, tunnel / clear
- 13224055: Entry Criteria: magnets installed
- 13224045A: Entry Criteria: magnets removed, tunnel clear / Steps: Pull East Arc Cable (done); Pull Sprdr Cable (done); Pull Recomb. Cable (done); Pull Ext. Cable (done); Pull BSY cable (done); Terminate East Arc (done); Terminate Sprdr (done); Terminate Recomb. (done); Terminate Ext (done); Terminate BSY (done)
- 13224090: Entry Criteria: magnets removed for pull, magnets in / place to connect & terminate
- 13224087: Entry Criteria: magnets removed for pull, magnets in / place to connect & terminate
- 23224045A: Entry Criteria: magnets removed, tunnel clear
- 23224045Aa: Entry Criteria: magnets removed, tunnel clear
- 23224045Ab: Entry Criteria: magnets removed, tunnel clear
- 23224055: Entry Criteria: magnets installed
- 23224055a: Entry Criteria: magnets installed
- 23224085A: Entry Criteria: magnets removed for pull, magnets in / place to connect & terminate
- 23224085Aa: Entry Criteria: magnets removed for pull, magnets in / place to connect & terminate
- 23224087: Entry Criteria: magnets removed for pull, magnets in / place to connect & terminate / Steps: LCW (done); Control wiring; AC Pwr; DC Cable (done)
- 23224087a: Entry Criteria: magnets removed for pull, magnets in / place to connect & terminate / Steps: LCW (done); Control wiring; AC Pwr; DC Cable (done)
- 23224100: Steps: Box Software Complete (done); Shunts Software Complete; Trims Software Complete (done); Test
- 23224100a: Steps: Box Software Complete (done); Shunts Software Complete; Trims Software Complete (done); Test

| ID | WBS | Activity | Duration | Start | Finish | Predecessors | Complete | Planned start | Planned finish | Resources | Cost | Actual cost | Calculated Remaining Total Cost | MONTHLY EV COST | RESP - Responsibility | STRT%COMP for CM EVM | FNSH%COMP for CM EVM | Profile change | Advance Purchase Plan > 500K | CR 08-016 | EVMS Reporting Codes | CAM RESPONSIBLE | 12 GEV MAJOR PROCUREMENT CATAGORY | Duplications | CR 09-012 | CR 10-039 | LOE Divider | LOE Multiplier | CR 07-024 | Remaining Material Cost Based on % Compl | Claimed Material Cost Based on % Complet | Initial Claimed Material Calc | Claimed Material Divider | Schedule Contingency | LOE % Pre Calc | LOE % | ReBaseline Actuals Adjustment |
| --- | --- | --- | --- | --- | --- | --- | --- | --- | --- | --- | --- | --- | --- | --- | --- | --- | --- | --- | --- | --- | --- | --- | --- | --- | --- | --- | --- | --- | --- | --- | --- | --- | --- | --- | --- | --- | --- |
|  | 3 | **1.3.3 CRYOGENICS** |  | 2009-04-16 | 2013-09-30 |  |  |  |  |  |  |  |  |  |  |  |  |  |  |  |  |  |  |  |  |  |  |  |  |  |  |  |  |  |  |  |  |
|  | 1 | **1.3.3.1 ACCELERATOR** |  | 2009-07-01 | 2013-09-30 |  |  |  |  |  |  |  |  |  |  |  |  |  |  |  |  |  |  |  |  |  |  |  |  |  |  |  |  |  |  |  |  |
|  | 01 | **1.3.3.1.01 COMPRESSORS** |  | 2010-03-08 | 2013-08-30 |  |  |  |  |  |  |  |  |  |  |  |  |  |  |  |  |  |  |  |  |  |  |  |  |  |  |  |  |  |  |  |  |
| 1331.01000 |  | Vend Production CHL Helium Compressors (Original Labor) | 6d | 2010-03-08 A | 2010-03-15 A | 12131.03020, 12131.03015, 9-100M FS+60d, 1331.02000 FS-125d | 100% |  |  | ELEC ENG [24.16 h]; TRAVEL; ELEC DES [24.16 h]; MECH ENG [24.16 h]; MECH DES [24.16 h] | 6,593.48 | 5,431.17 | 0 | 6593.478 | ARENIUS D | 1 | 1 | C | APP | 08-016 | H | DANA A | 3311 | DUP | 09-012 | 10-039 |  |  |  |  |  |  |  |  |  |  |  |
| 1331.01005 |  | Vend Production CHL Helium Compressors Oversight FY10 | 145.07d | 2010-03-08 A | 2010-09-30 A | 9-100M FS+102d, 1331.01000 | 100% |  |  | MECH TECH [273 h]; TRAVEL; ELEC TECH [102.5 h]; ELEC ENG [58 h]; ELEC DES [58 h]; MECH ENG [58 h]; MECH DES [58 h] | 35,243.45 | 28,682.05 | 0 | 35243.445 | ARENIUS D | 1 | 1 | C | APP |  | E | DANA A | 3311 | DUP |  | 10-039 | 100 | 100 | 07-024 |  |  |  |  |  |  |  |  |
| 1331.01010 |  | Vend Fab CHL Helium Compressors Peg Point #1 Complete Preliminary Design Review | 16d | 2010-03-08 A | 2010-03-29 A | 9-100M FS+102d | 100% |  |  | PROCUREMENT<$50K 60 NO ESCALATION; PROCUREMENT>$50K 69 NO ESCALATION | 138,308.78 |  | 0 | 138308.78 | ARENIUS D | 1 | 1 | C | APP |  | P | DANA A | 3311 |  |  | 10-039 |  |  |  | 0 | 138308.78 | 13830878 | 100 |  |  |  |  |
| 1331.01015 |  | Vend Fab CHL Helium Compressors Peg Point #2 Placement of Order for Coolers | 36d | 2010-03-08 A | 2010-04-26 A | 1331.01010 FS-40d | 100% |  |  | PROCUREMENT>$50K 69 NO ESCALATION | 110,647.02 |  | 0 | 110647.02 | ARENIUS D | 1 | 1 | C | APP |  | P | DANA A | 3311 |  |  | 10-039 |  |  |  | 0 | 110647.02 | 11064702 | 100 |  |  |  |  |
| 1331.01020 |  | Vend Fab CHL Helium Compressors Peg Point #3 Placement of Order for Compressors | 36d | 2010-03-08 A | 2010-04-26 A | 1331.01015 FS-40d | 100% |  |  | PROCUREMENT>$50K 69 NO ESCALATION | 313,499.89 |  | 0 | 313499.89 | ARENIUS D | 1 | 1 | C | APP |  | P | DANA A | 3311 |  |  | 10-039 |  |  |  | 0 | 313499.89 | 31349989 | 100 |  |  |  |  |
| 1331.01025 |  | Vend Fab CHL Helium Compressors Peg Point #4 Placement of Order for Heat Exchangers | 40d | 2010-03-08 A | 2010-04-30 A | 1331.01020 FS-40d | 100% |  |  | PROCUREMENT>$50K 69 NO ESCALATION | 204,696.99 |  | 0 | 204696.99 | ARENIUS D | 1 | 1 | C | APP |  | P | DANA A | 3311 |  |  | 10-039 |  |  |  | 0 | 204696.99 | 20469699 | 100 |  |  |  |  |
| 1331.01030 |  | Vend Fab CHL Helium Compressors Peg Point #5 Placement of Order for Motors | 36d | 2010-03-08 A | 2010-04-26 A | 1331.01025 FS-60d | 100% |  |  | PROCUREMENT>$50K 69 NO ESCALATION | 313,499.89 |  | 0 | 313499.89 | ARENIUS D | 1 | 1 | C | APP |  | P | DANA A | 3311 |  |  | 10-039 |  |  |  | 0 | 313499.89 | 31349989 | 100 |  |  |  |  |
| 1331.01035 |  | Vend Fab CHL Helium Compressors Peg Point #6 CDR Complete | 196d | 2010-03-08 A | 2010-12-13 A | 1331.01030 FS-60d | 100% |  |  | PROCUREMENT>$50K 69 NO ESCALATION | 138,308.78 |  | 0 | 138308.78 | ARENIUS D | 1 | 1 | C | APP |  | P | DANA A | 3311 |  |  | 10-039 |  |  |  | 0 | 138308.78 | 13830878 | 100 |  |  |  |  |
| 1331.01040 |  | Vend Fab CHL Helium Compressors Peg Point #7 Final Drawing Approval | 219d | 2010-03-08 A | 2011-01-24 A | 1331.01035 FS-82d | 100% |  |  | PROCUREMENT>$50K 69 NO ESCALATION | 184,411.7 |  | 0 | 184411.7 | ARENIUS D | 1 | 1 | C | APP |  | P | DANA A | 3311 |  |  | 10-039 |  |  |  | 0 | 184411.7 | 18441170 | 100 | SC |  |  |  |
| 1331.01045 |  | Vend Fab CHL Helium Compressors Peg Point #8 Receipt of Compressors | 156d | 2010-03-08 A | 2010-10-14 A | 1331.01040 FS-125d | 100% |  |  | PROCUREMENT>$50K 69 NO ESCALATION | 424,146.91 |  | 0 | 424146.91 | ARENIUS D | 1 | 1 | C | APP |  | P | DANA A | 3311 |  |  | 10-039 |  |  |  | 0 | 424146.91 | 42414691 | 100 | SC |  |  |  |
| 1331.01050 |  | Vend Fab CHL Helium Compressors Peg Point #9 Receipt of Motors | 178d | 2010-03-08 A | 2010-11-15 A | 1331.01045 FS-146d | 100% |  |  | PROCUREMENT>$50K 69 NO ESCALATION | 424,146.91 |  | 0 | 424146.91 | ARENIUS D | 1 | 1 | C | APP |  | P | DANA A | 3311 |  |  | 10-039 |  |  |  | 0 | 424146.91 | 42414691 | 100 | SC |  |  |  |
| 1331.01055 |  | Vend Fab CHL Helium Compressors Peg Point #10 Receipt of Heat Exchangers | 404d | 2010-03-08 A | 2011-10-15 A | 1331.01050 FS-167d | 100% | 2010-03-08 | 2011-10-14 | PROCUREMENT>$50K 69 NO ESCALATION | 238,813.15 |  | 0 | 238813.15 | ARENIUS D | 1 | 1 | C | APP |  | D | DANA A | 3311 |  |  | 10-039 |  |  |  | 0 | 238813.15 | 23881315 | 100 | SC |  |  |  |
| 1331.01060 |  | Vend Fab CHL Helium Compressors Peg Point #11 Receipt of Coolers | 420d | 2010-03-08 A | 2011-11-07 A | 1331.01055 FS-167d | 100% |  |  | PROCUREMENT>$50K 69 NO ESCALATION | 238,813.15 |  | 0 | 238813.15 | ARENIUS D | 1 | 1 | C | APP |  | D | DANA A | 3311 |  |  | 10-039 |  |  |  | 0 | 238813.15 | 23881315 | 100 | SC |  |  |  |
| 1331.01065 |  | Vend Fab CHL Helium Compressors Peg Point #12 Complete Installation of Motors | 262d | 2010-03-08 A | 2011-03-25 A | 1331.01060 FS-204d | 100% |  |  | PROCUREMENT>$50K 69 NO ESCALATION | 276,617.55 |  | 0 | 276617.55 | ARENIUS D | 1 | 1 | C | APP |  | P | DANA A | 3311 |  |  | 10-039 |  |  |  | 0 | 276617.55 | 27661755 | 100 | SC |  |  |  |
| 1331.01070 |  | Vend Fab CHL Helium Compressors Peg Point #13 Complete Installation of Compressors | 262d | 2010-03-08 A | 2011-03-25 A | 1331.01065 FS-224d | 100% |  |  | PROCUREMENT>$50K 69 NO ESCALATION | 258,176.38 |  | 0 | 258176.38 | ARENIUS D | 1 | 1 | C | APP |  | P | DANA A | 3311 |  |  | 10-039 |  |  |  | 0 | 258176.38 | 25817638 | 100 | SC |  |  |  |
| 1331.01075 |  | Vend Fab CHL Helium Compressors Peg Point #14 Complete Installation of Coolers | 432d | 2010-03-08 A | 2011-11-23 A | 1331.01070 FS-224d | 100% |  |  | PROCUREMENT>$50K 69 NO ESCALATION | 92,205.85 |  | 0 | 92205.85 | ARENIUS D | 1 | 1 | C | APP |  | D | DANA A | 3311 |  |  | 10-039 |  |  |  | 0 | 92205.85 | 9220585 | 100 | SC |  |  |  |
| 1331.01080 |  | Vend Fab CHL Helium Compressors Peg Point #15 Complete Installation of Heat Exchangers | 432d | 2010-03-08 A | 2011-11-23 A | 1331.01075 FS-224d | 100% |  |  | PROCUREMENT>$50K 69 NO ESCALATION | 92,205.85 |  | 0 | 92205.85 | ARENIUS D | 1 | 1 | C | APP |  | D | DANA A | 3311 |  |  | 10-039 |  |  |  | 0 | 92205.85 | 9220585 | 100 | SC |  |  |  |
| 1331.01085 |  | Vend Fab CHL Helium Compressors Peg Point #16 System Pressure, Leak Test | 443d | 2010-03-08 A | 2011-12-12 A | 1331.01080 FS-243d | 100% |  |  | PROCUREMENT>$50K 69 NO ESCALATION | 92,205.85 |  | 0 | 92205.85 | ARENIUS D | 1 | 1 | C | APP |  | D | DANA A | 3311 |  |  | 10-039 |  |  |  | 0 | 92205.85 | 9220585 | 100 | SC |  |  |  |
| 1331.01090 |  | Vend Fab CHL Helium Compressors Peg Point #17 Installation of Electrical Panels, Instruments and Devices | 283d | 2010-03-08 A | 2011-04-25 A | 1331.01085 FS-243d | 100% |  |  | PROCUREMENT>$50K 69 NO ESCALATION | 92,205.85 |  | 0 | 92205.85 | ARENIUS D | 1 | 1 | C | APP |  | P | DANA A | 3311 |  |  | 10-039 |  |  |  | 0 | 92205.85 | 9220585 | 100 | SC |  |  |  |
| 1331.01095 |  | Vend Fab CHL Helium Compressors Peg Point #18 Spare Parts Received by JLab | 314d | 2010-03-08 A | 2011-06-08 A | 1331.01090 FS-243d | 100% |  |  | PROCUREMENT>$50K 69 NO ESCALATION | 57,206.7 |  | 0 | 57206.7 | ARENIUS D | 1 | 1 | C | APP |  | P | DANA A | 3311 |  |  | 10-039 |  |  |  | 0 | 57206.7 | 5720670 | 100 | SC |  |  |  |
| 1331.01100 |  | Vend Fab CHL Helium Compressors Peg Point #19 Complete User Rediness Review | 631d | 2010-03-08 A | 2012-09-14 A | 1331.01095 FS-266d | 100% |  |  | PROCUREMENT>$50K 69 NO ESCALATION | 18,441.17 |  | 0 | 18441.17 | ARENIUS D | 1 | 1 | C | APP |  | P | DANA A | 3311 |  |  | 10-039 |  |  |  | 0 | 18441.17 | 1844117 | 100 | SC |  |  |  |
| 1331.01105 |  | Vend Fab CHL Helium Compressors Peg Point #20 Completion of Compressor System Commissioning | 631d | 2010-03-08 A | 2012-09-14 A | 1331.01100 FS-350d | 100% |  |  | PROCUREMENT>$50K 69 NO ESCALATION | 18,441.17 |  | 0 | 18441.17 | ARENIUS D | 1 | 1 | C | APP |  | P | DANA A | 3311 |  |  | 10-039 |  |  |  | 0 | 18441.17 | 1844117 | 100 | SC |  |  |  |
| 1331.01110 |  | Vend Fab CHL Helium Compressors Peg Point #21 Completion of System Acceptance Testing and Report | 631d | 2010-03-08 A | 2012-09-14 A | 1331.01105 FS-350d | 100% |  |  | PROCUREMENT>$50K 69 NO ESCALATION | 18,441.16 |  | 0 | 18441.16 | ARENIUS D | 1 | 1 | C | APP |  | P | DANA A | 3311 |  |  | 10-039 |  |  |  | 0 | 18441.16 | 1844116 | 100 | SC |  |  |  |
| 1331.01005A |  | Vend Production CHL Helium Compressors Oversight FY11 | 184d | 2010-10-01 A | 2011-06-30 A | 1331.01005 | 100% |  |  | MECH DES [77.84 h]; MECH ENG [77.84 h]; MECH TECH [367 h]; TRAVEL; ELEC TECH [137.5 h]; ELEC DES [77.84 h]; ELEC ENG [77.84 h] | 46,514.04 | 39,743.34 | 0 | 46514.0314 | ARENIUS D | 1 | 1 | C | APP |  | E | DANA A | 3311 |  |  | 10-039 | 100 | 100 |  |  |  |  |  |  | 11.95652173 | 88.04347826 |  |
| 1331.01115 |  | Re-Baseline Actuals Adjustment | 1d | 2013-08-30 A | 2013-08-30 A |  | 100% | 2013-09-03 | 2013-09-03 | PROCUREMENT>$50K 69 NO ESCALATION | 303,464.42 |  |  | 303464.42 |  |  |  |  |  |  |  |  |  |  |  |  |  |  |  | 0 | 303464.42 | 30346442 | 100 |  |  |  | ADJ |

Notes:
- 1331.01000: Entry Criteria: Ext Pred: Completion of ACD
- 1331.01005: Entry Criteria: Ext Pred: Completion of ACD
- 1331.01010: Entry Criteria: Ext Pred: Completion of ACD
- 1331.01015: Entry Criteria: Ext Pred: Completion of ACD
- 1331.01020: Entry Criteria: Ext Pred: Completion of ACD
- 1331.01025: Entry Criteria: Ext Pred: Completion of ACD
- 1331.01030: Entry Criteria: Ext Pred: Completion of ACD
- 1331.01035: Entry Criteria: Ext Pred: Completion of ACD
- 1331.01040: Entry Criteria: Ext Pred: Completion of ACD
- 1331.01045: Entry Criteria: Ext Pred: Completion of ACD
- 1331.01050: Entry Criteria: Ext Pred: Completion of ACD
- 1331.01055: Entry Criteria: Ext Pred: Completion of ACD
- 1331.01060: Entry Criteria: Ext Pred: Completion of ACD
- 1331.01065: Entry Criteria: Ext Pred: Completion of ACD
- 1331.01070: Entry Criteria: Ext Pred: Completion of ACD
- 1331.01075: Entry Criteria: Ext Pred: Completion of ACD
- 1331.01080: Entry Criteria: Ext Pred: Completion of ACD
- 1331.01085: Entry Criteria: Ext Pred: Completion of ACD
- 1331.01090: Entry Criteria: Ext Pred: Completion of ACD
- 1331.01095: Entry Criteria: Ext Pred: Completion of ACD
- 1331.01100: Entry Criteria: Ext Pred: Completion of ACD
- 1331.01105: Entry Criteria: Ext Pred: Completion of ACD
- 1331.01110: Entry Criteria: Ext Pred: Completion of ACD
- 1331.01005A: Entry Criteria: Ext Pred: Completion of ACD

| ID | WBS | Activity | Duration | Start | Finish | Predecessors | Complete | Planned start | Planned finish | Resources | Cost | Actual cost | Calculated Remaining Total Cost | MONTHLY EV COST | RESP - Responsibility | STRT%COMP for CM EVM | FNSH%COMP for CM EVM | Profile change | Advance Purchase Plan > 500K | CR 08-016 | EVMS Reporting Codes | CAM RESPONSIBLE | 12 GEV MAJOR PROCUREMENT CATAGORY | CR 09-012 | CR 09-053 | Remaining Material Cost Based on % Compl | Claimed Material Cost Based on % Complet | Initial Claimed Material Calc | Claimed Material Divider | Activities with Steps | Phil Dev | CR 12-018 | CR 12-029 | OPC Allison | MARCH!!! | LOE Divider | LOE Multiplier | CR 10-038 | CR 10-055 | LOE % Pre Calc | LOE % | CR 11-008 | CR 12-002 | ReBaseline Actuals Adjustment |
| --- | --- | --- | --- | --- | --- | --- | --- | --- | --- | --- | --- | --- | --- | --- | --- | --- | --- | --- | --- | --- | --- | --- | --- | --- | --- | --- | --- | --- | --- | --- | --- | --- | --- | --- | --- | --- | --- | --- | --- | --- | --- | --- | --- | --- |
|  | 02 | **1.3.3.1.02 COLD BOXES** |  | 2009-09-30 | 2013-08-30 |  |  |  |  |  |  |  |  |  |  |  |  |  |  |  |  |  |  |  |  |  |  |  |  |  |  |  |  |  |  |  |  |  |  |  |  |  |  |  |
| 1331.02000 |  | FY-09 Initial Labor (Planned) Procurement Support | 1d | 2009-09-30 A | 2009-09-30 A | 9-090M FS+60d, 12131.04020 | 100% |  |  | MECH ENG [151.61 h]; TRAVEL; MECH DES [151.61 h]; SUPPLIES & MATERIALS; ELEC DES [90.97 h]; ELEC TECH [90.97 h]; MECH TECH [272.9 h] | 44,649.29 | 35,196.96 | 0 | 44649.28795 | ARENIUS D | 1 | 1 | C | APP | 08-016 | H | DANA A | 3312 | 09-012 | 09-053 |  |  |  |  |  |  |  |  |  |  |  |  |  |  |  |  |  |  |  |
| 1331.02015 |  | Vend Fab- Peg Point 1: Contract Award | 1d | 2009-09-30 A | 2009-09-30 A | 1331.02000 FS-188d | 100% |  |  | PROCUREMENT>$50K 69 NO ESCALATION; PROCUREMENT<$50K 60 NO ESCALATION | 529,000 |  | 0 | 529000 | ARENIUS D | 1 | 1 | C | APP |  | P | DANA A | 3312 |  | 09-053 | 0 | 529000 | 52900000 | 100 |  |  |  |  |  |  |  |  |  |  |  |  |  |  |  |
| 1331.02020 |  | Vend Fab- Peg Point 3: Issue PO for Platefin Heat Exchangers& Absorbers | 103d | 2009-09-30 A | 2010-03-05 A | 1331.02015 FS-1d | 100% |  |  | PROCUREMENT>$50K 69 NO ESCALATION | 529,000 |  | 0 | 529000 | ARENIUS D | 1 | 1 | C | APP |  | S | DANA A | 3312 |  | 09-053 | 0 | 529000 | 52900000 | 100 | NB |  |  |  |  |  |  |  |  |  |  |  |  |  |  |
| 1331.02025 |  | Vend Fab- Peg Point 2: Complete Preliminary Design Review | 87d | 2009-09-30 A | 2010-02-10 A | 1331.02020 FS-79d, 1331.02015 FS-1d | 100% |  |  | PROCUREMENT>$50K 69 NO ESCALATION | 1,058,000 |  | 0 | 1058000 | ARENIUS D | 1 | 1 | C | APP |  | P | DANA A | 3312 |  | 09-053 | 0 | 1058000 | 105800000 | 100 |  |  |  |  |  |  |  |  |  |  |  |  |  |  |  |
| 1331.02030 |  | Vend Fab- Peg Point 4: Issue PO for Turbines & Cryogenic Valves | 139d | 2009-09-30 A | 2010-04-26 A | 1331.02025 FS-79d, 1331.02015 FS-1d | 100% |  |  | PROCUREMENT>$50K 69 NO ESCALATION | 529,000 |  | 0 | 529000 | ARENIUS D | 1 | 1 | C | APP |  | P | DANA A | 3312 |  | 09-053 | 0 | 529000 | 52900000 | 100 |  |  |  |  |  |  |  |  |  |  |  |  |  |  |  |
| 1331.02035 |  | Vend Fab- Peg Point 7: Deliver Platefin Heat Exchangers& Absorbers | 246d | 2009-09-30 A | 2010-09-27 A | 1331.02015 FS-1d, 1331.02030 FS-143d | 100% |  |  | PROCUREMENT>$50K 69 NO ESCALATION | 1,058,000 |  | 0 | 1058000 | ARENIUS D | 1 | 1 | C | APP |  | P | DANA A | 3312 |  | 09-053 | 0 | 1058000 | 105800000 | 100 |  |  |  |  |  |  |  |  |  |  |  |  |  |  |  |
| 1331.02040 |  | Vend Fab- Peg Point 4: Issue PO for Cold Box Shell | 281d | 2009-09-30 A | 2010-11-15 A | 1331.02035 FS-249d, 1331.02015 FS-1d | 100% |  |  | PROCUREMENT>$50K 69 NO ESCALATION | 529,000 |  | 0 | 529000 | ARENIUS D | 1 | 1 | C | APP |  | P | DANA A | 3312 |  | 09-053 | 0 | 529000 | 52900000 | 100 |  |  |  |  |  |  |  |  |  |  |  |  |  |  |  |
| 1331.02045 |  | Vend Fab- Peg Point 8: Deliver Turbine Housing | 246d | 2009-09-30 A | 2010-09-27 A | 1331.02015 FS-1d, 1331.02040 FS-249d | 100% |  |  | PROCUREMENT>$50K 69 NO ESCALATION | 952,200 |  | 0 | 952200 | ARENIUS D | 1 | 1 | C | APP |  | P | DANA A | 3312 |  | 09-053 | 0 | 952200 | 95220000 | 100 |  |  |  |  |  |  |  |  |  |  |  |  |  |  |  |
| 1331.02050 |  | Vend Fab- Peg Point 5: Complete Final Design Review | 249d | 2009-09-30 A | 2010-09-30 A | 1331.02045 FS-290d, 1331.02015 FS-1d | 100% |  |  | PROCUREMENT>$50K 69 NO ESCALATION | 529,000 |  | 0 | 529000 | ARENIUS D | 1 | 1 | C | APP |  | P | DANA A | 3312 |  | 09-053 | 0 | 529000 | 52900000 | 100 |  |  |  |  |  |  |  |  |  |  |  |  |  |  |  |
| 1331.02055 |  | Vend Fab- Peg Point 10: Complete Internal Piping | 428d | 2009-09-30 A | 2011-06-23 A | 1331.02015 FS-1d, 1331.02050 FS-308d | 100% |  |  | PROCUREMENT>$50K 69 NO ESCALATION | 952,200 |  | 0 | 952200 | ARENIUS D | 1 | 1 | C | APP |  | P | DANA A | 3312 |  | 09-053 | 0 | 952200 | 95220000 | 100 |  |  |  |  |  |  |  |  |  |  |  |  |  |  |  |
| 1331.02060 |  | Vend Fab- Peg Point 9: Complete Cold Box Shell | 411d | 2009-09-30 A | 2011-05-31 A | 1331.02055 FS-433d, 1331.02015 FS-1d | 100% |  |  | PROCUREMENT>$50K 69 NO ESCALATION | 952,200 |  | 0 | 952200 | ARENIUS D | 1 | 1 | C | APP |  | P | DANA A | 3312 |  | 09-053 | 0 | 952200 | 95220000 | 100 |  |  |  |  |  |  |  |  |  |  |  |  |  |  |  |
| 1331.02065 |  | Vend Fab- Peg Point 11: Ship Cold Box | 602d | 2009-09-30 A | 2012-03-09 A | 1331.02090 FS-476d, 1331.02060 FS-433d, 1331.02015 FS-1d, 1331.02085 FS-108d | 100% |  |  | PROCUREMENT>$50K 69 NO ESCALATION | 1,481,200 |  | 0 | 1481200 | ARENIUS D | 1 | 1 | C | APP |  | D | DANA A | 3312 |  | 09-053 | 0 | 1481200 | 148120000 | 100 |  |  |  |  |  |  |  |  |  |  |  |  |  |  |  |
| 1331.02070 |  | Vend Fab- Peg Point 12: Complete Installation | 715d | 2009-09-30 A | 2012-08-17 A | 1331.02068 FS-497d, 1331.02065 FS-476d, 1331.02015 FS-1d | 100% |  |  | PROCUREMENT>$50K 69 NO ESCALATION | 423,200 |  | 0 | 423200 | ARENIUS D | 1 | 1 | C | APP |  | S | DANA A | 3312 |  | 09-053 | 0 | 423200 | 42320000 | 100 | ST | MP |  |  |  |  |  |  |  |  |  |  |  |  |  |
| 1331.02075 |  | Vend Fab- Peg Point 14: Deliver Final Operating & Maintenance Manuals | 735d | 2009-09-30 A | 2012-09-17 A | 1331.02015 FS-1d, 1331.02070 FS-497d | 100% |  |  | PROCUREMENT>$50K 69 NO ESCALATION | 211,600 |  | 0 | 211600 | ARENIUS D | 1 | 1 | C | APP |  | P | DANA A | 3312 |  | 09-053 | 0 | 211600 | 21160000 | 100 |  |  | 12-018F | 12-029F |  |  |  |  |  |  |  |  |  |  |  |
| 1331.02080 |  | Vend Fab Peg Point 13: Acceptance Test Complete & Report Delivered | 835d | 2009-09-30 A | 2013-08-15 A | 1331.02075 FS-518d, 1331.02015 FS-1d | 100% | 2009-09-30 | 2013-02-15 | PROCUREMENT>$50K 69 NO ESCALATION | 846,400 |  | 846400 | 846400 | ARENIUS D | 1 | 1 | C | APP |  | P | DANA A | 3312 |  | 09-053 | 0 | 846400 | 84640000 | 100 |  | MP | 12-018F | 12-029F | OPC A | XX |  |  |  |  |  |  |  |  |  |
| 1331.02001 |  | FY-10 Labor Procurement Support | 247d | 2009-10-02 A | 2010-09-30 A | 1331.02000 FS-188d, 9-100M | 100% |  |  | SUPPLIES & MATERIALS; ELEC DES [92.21 h]; ELEC TECH [92.21 h]; MECH TECH [276.63 h]; MECH ENG [132.21 h]; TRAVEL; MECH DES [132.21 h] | 44,552.59 | 34,429.79 | 0 | 44552.592071 | ARENIUS D | 1 | 1 | C | APP |  | E | DANA A | 3312 |  | 09-053 |  |  |  |  |  |  |  |  |  |  | 100 | 100 |  |  |  |  |  |  |  |
| 1331.02012 |  | He Dewar Procurement | 183d | 2010-03-01 A | 2010-11-15 A | 9-100M FS+10d | 100% |  |  | PROCUREMENT<$50K 60 NO ESCALATION; PROCUREMENT>$50K 69 NO ESCALATION | 123,000 |  | 0 | 123000 | ARENIUS D | 1 | 1 | C | APP |  | P | DANA A | 3312 |  | 09-053 | 0 | 123000 | 12300000 | 100 |  |  |  |  |  |  |  |  |  |  |  |  |  |  |  |
| 1331.02085 |  | Additional Funds for Currency Exchange Rate | 10d | 2010-03-01 A | 2010-03-12 A | 9-100M FS+97d | 100% |  |  | PROCUREMENT>$50K 69 NO ESCALATION; PROCUREMENT<$50K 60 NO ESCALATION | 255,826 |  | 0 | 255826 | ARENIUS D | 1 | 1 | C | APP |  | P | DANA A | 3312 |  |  | 0 | 255826 | 25582600 | 100 |  |  |  |  |  |  |  |  | 10-038 |  |  |  |  |  |  |
| 1331.02090 |  | Spare Turbine and Seal Kits | 53d | 2010-03-17 A | 2010-05-28 A | 9-100M FS+97d | 100% |  |  | PROCUREMENT>$50K 69 NO ESCALATION; PROCUREMENT<$50K 60 NO ESCALATION | 690,785 |  | 0 | 690785 | ARENIUS D | 1 | 1 | C | APP |  | P | DANA A | 3312 |  |  | 0 | 690785 | 69078500 | 100 |  |  |  |  |  |  |  |  | 10-038 | 10-055 |  |  |  |  |  |
| 1331.02005 |  | FY-11 Labor Procurement Support | 248d | 2010-10-01 A | 2011-09-30 A | 9-100M FS+60d, 1331.02001, 32-02M FS+125d, 1331.02000 | 100% |  |  | TRAVEL; MECH TECH [276.63 h]; ELEC TECH [92.21 h]; SUPPLIES & MATERIALS; MECH ENG [132.21 h]; MECH DES [132.21 h]; ELEC DES [92.21 h] | 45,972.39 | 35,526.67 | 0 | 45972.386737 | ARENIUS D | 1 | 1 | C | APP | 08-016 | E | DANA A | 3312 | 09-012 | 09-053 |  |  |  |  |  |  |  |  |  |  | 100 | 100 |  |  | 8.46774193 | 91.53225806 |  |  |  |
| 1331.02052 |  | Vend Fab- Peg Point 15: Venturi Flow Measurement | 78d | 2011-01-04 A | 2011-04-25 A | 1331.02050 | 100% |  |  | PROCUREMENT<$50K 60 NO ESCALATION | 33,800 |  | 0 | 33800 | ARENIUS D | 1 | 1 | C | APP |  | P | DANA A | 3312 |  | 09-053 | 0 | 33800 | 3380000 | 100 |  |  |  |  |  |  |  |  |  |  |  |  | 11-008 |  |  |
| 1331.02068 |  | Vend Fab- Peg Point 16: Re-rout Transfer Lines | 103d | 2011-01-04 A | 2011-05-31 A | 1331.02065 FS-168d, 1331.02052 FS-85d | 100% |  |  | PROCUREMENT>$50K 69 NO ESCALATION; PROCUREMENT<$50K 60 NO ESCALATION | 97,200 |  | 0 | 97200 | ARENIUS D | 1 | 1 | C | APP |  | P | DANA A | 3312 |  | 09-053 | 0 | 97200 | 9720000 | 100 |  |  |  |  |  |  |  |  |  |  |  |  | 11-008 |  |  |
| 1331.02010 |  | FY-12 Labor Procurement Support | 120d | 2011-10-03 A | 2012-03-30 A | 9-110M FS+60d, 1331.02005 | 100% |  |  | ELEC DES [44.62 h]; ELEC TECH [44.62 h]; MECH ENG [63.97 h]; TRAVEL; MECH DES [63.97 h]; MECH TECH [133.85 h]; SUPPLIES & MATERIALS | 26,358.04 | 17,737.52 | 0 | 26358.049403 | ARENIUS D | 1 | 1 |  | APP | 08-016 | E | DANA A | 3312 | 09-012 | 09-053 |  |  |  |  |  |  |  |  |  |  | 100 | 100 |  |  | 18.33333333 | 81.66666666 |  |  |  |
| 1331.02066 |  | Vend Fab- Peg Point 17: Cold Box Shipping Costs | 89d | 2011-11-01 A | 2012-03-16 A | 1331.02065 FS-30d | 100% |  |  | PROCUREMENT>$50K 69 NO ESCALATION; PROCUREMENT<$50K 60 NO ESCALATION | 250,000 |  | 0 | 250000 | ARENIUS D | 1 | 1 | C | APP |  | D | DANA A | 3312 |  |  | 0 | 250000 | 25000000 | 100 |  |  | 12-018F | 12-029F |  |  |  |  |  |  |  |  |  | 12-002 |  |
| 1331.02100 |  | Re-Baseline Actuals Adjustment | 1d | 2013-08-30 A | 2013-08-30 A |  | 100% | 2013-09-03 | 2013-09-03 | PROCUREMENT>$50K 69 NO ESCALATION | 210,640.2 |  |  | 210640.2 |  |  |  |  |  |  |  |  |  |  |  | 0 | 210640.2 | 21064020 | 100 |  |  |  |  |  |  |  |  |  |  |  |  |  |  | ADJ |

Notes:
- 1331.02000: Entry Criteria: Ext Pred: Completion of ACD
- 1331.02015: Entry Criteria: Ext Pred: Completion of ACD
- 1331.02020: Entry Criteria: Ext Pred: Completion of ACD / Heat Exchangers 85% / Absorbers 15%
- 1331.02025: Entry Criteria: Ext Pred: Completion of ACD
- 1331.02030: Entry Criteria: Ext Pred: Completion of ACD
- 1331.02035: Entry Criteria: Ext Pred: Completion of ACD
- 1331.02040: Entry Criteria: Ext Pred: Completion of ACD
- 1331.02045: Entry Criteria: Ext Pred: Completion of ACD
- 1331.02050: Entry Criteria: Ext Pred: Completion of ACD
- 1331.02055: Entry Criteria: Ext Pred: Completion of ACD
- 1331.02060: Entry Criteria: Ext Pred: Completion of ACD
- 1331.02065: Entry Criteria: Ext Pred: Completion of ACD
- 1331.02070: Entry Criteria: Ext Pred: Completion of ACD / Steps: Erect cold box platform (done); Install Instrument rack, control panels (done); Mount cold box valve actuators and install instrument air/process tubing (done); Install absorber bed charcoal and temperature sensors (done); Install piping to JLab utility manifolds (air, water, clean helium, recovery gas, etc) (done); Install piping to JLab vaporizer (done); Install Vacuum Pump Equipment (done); Install Cold Box to Cold Box Transfer Line (done)
- 1331.02075: Entry Criteria: Ext Pred: Completion of ACD
- 1331.02080: Entry Criteria: Ext Pred: Completion of ACD
- 1331.02001: Entry Criteria: Ext Pred: Completion of ACD
- 1331.02012: Entry Criteria: Ext Pred: Completion of ACD
- 1331.02085: Entry Criteria: Ext Pred: Completion of ACD
- 1331.02090: Entry Criteria: Ext Pred: Completion of ACD
- 1331.02005: Entry Criteria: Ext Pred: Completion of ACD
- 1331.02052: Entry Criteria: Ext Pred: Completion of ACD
- 1331.02068: Entry Criteria: Ext Pred: Completion of ACD
- 1331.02010: Entry Criteria: Ext Pred: Completion of ACD

| ID | WBS | Activity | Duration | Start | Finish | Predecessors | Complete | Planned start | Planned finish | Calendar | Resources | Cost | Actual cost | Remaining Material Cost Based on % Compl | Claimed Material Cost Based on % Complet | Initial Claimed Material Calc | Claimed Material Divider | Calculated Remaining Total Cost | MONTHLY EV COST | RESP - Responsibility | STRT%COMP for CM EVM | FNSH%COMP for CM EVM | EVMS Reporting Codes | CAM RESPONSIBLE | Activities with Steps | ReBaseline Actuals Adjustment | Notebook Entry for S | Advance Purchase Plan > 500K | CR 08-016 | 12 GEV MAJOR PROCUREMENT CATAGORY | Installation | CR 09-012 | CR 11-001 | CR 13-003 | Original Activity ID Rebaseline | PRIOR MONTH EV COST | BOE Procurement | BOE Labor | BOE Expenses | BOE Adder | CR 13-015 | Post Rebaseline | Obligated Prior to Rebaseline |
| --- | --- | --- | --- | --- | --- | --- | --- | --- | --- | --- | --- | --- | --- | --- | --- | --- | --- | --- | --- | --- | --- | --- | --- | --- | --- | --- | --- | --- | --- | --- | --- | --- | --- | --- | --- | --- | --- | --- | --- | --- | --- | --- | --- |
|  | 03 | **1.3.3.1.03 OIL REMOVAL SKIDS** |  | 2010-02-08 | 2013-08-30 |  |  |  |  |  |  |  |  |  |  |  |  |  |  |  |  |  |  |  |  |  |  |  |  |  |  |  |  |  |  |  |  |  |  |  |  |  |  |
| 1331.03000 |  | Fab Oil Removl Skids | 197d | 2010-02-08 A | 2010-11-15 A | 32-03M FS-60d | 100% |  |  |  | ELEC TECH [120 h]; PROCUREMENT>$50K 69; PROCUREMENT<$50K 60; MECH ENG [40 h]; MECH DES [40 h]; MECH TECH [400 h]; ELEC ENG [40 h] | 428,817.41 | 28,913.26 | 0 | 399904.15 | 39990415 | 100 | 0 | 429584.95 | ARENIUS D | 1 | 1 | S | DANA A | ST |  |  |  |  |  |  |  |  |  |  |  |  |  |  |  |  |  |  |
| 1331.03005 |  | Re-Baseline Actuals Adjustment | 1d | 2013-08-30 A | 2013-08-30 A |  | 100% | 2013-09-03 | 2013-09-03 |  | PROCUREMENT>$50K 69 NO ESCALATION | -67,258.9 |  |  |  |  | 100 |  |  |  |  |  |  |  |  | ADJ |  |  |  |  |  |  |  |  |  |  |  |  |  |  |  |  |  |
|  | 04 | **1.3.3.1.04 I & C** |  |  |  |  |  |  |  |  |  |  |  |  |  |  |  |  |  |  |  |  |  |  |  |  |  |  |  |  |  |  |  |  |  |  |  |  |  |  |  |  |  |
|  | 05 | **1.3.3.1.05 Not Used** |  |  |  |  |  |  |  |  |  |  |  |  |  |  |  |  |  |  |  |  |  |  |  |  |  |  |  |  |  |  |  |  |  |  |  |  |  |  |  |  |  |
|  | 06 | **1.3.3.1.06 CHL GAS MANAGEMENT RACK** |  | 2009-07-01 | 2013-08-30 |  |  |  |  |  |  |  |  |  |  |  |  |  |  |  |  |  |  |  |  |  |  |  |  |  |  |  |  |  |  |  |  |  |  |  |  |  |  |
| 1331.06000 |  | Fab CHL Gas Mngmnt Rack | 309d | 2009-07-01 A | 2010-09-27 A | 9-090M | 100% |  |  |  | MECH DES [40 h]; ELEC ENG [40 h]; MECH TECH [600 h]; PROCUREMENT<$50K 60; ELEC TECH [240 h]; SUPPLIES & MATERIALS; MECH ENG [40 h] | 151,073.55 | 41,817.06 | 0 | 81636.23 | 8163623 | 100 | 0 | 152683.69 | ARENIUS D | 1 | 1 | S | DANA A | NB |  | Notebook Entry for S |  |  |  |  |  |  |  |  |  |  |  |  |  |  |  |  |
| 1331.06005 |  | Re-Baseline Actuals Adjustment | 1d | 2013-08-30 A | 2013-08-30 A |  | 100% | 2013-09-03 | 2013-09-03 |  | PROCUREMENT>$50K 69 NO ESCALATION | 52,367.6 |  | 0 | 52367.6 | 5236760 | 100 |  | 52367.6 |  |  |  |  |  |  | ADJ |  |  |  |  |  |  |  |  |  |  |  |  |  |  |  |  |  |
|  | 07 | **1.3.3.1.07 CHL SYSTEM INSTRUMENTATION & CONTROL** |  | 2009-08-27 | 2013-08-30 |  |  |  |  |  |  |  |  |  |  |  |  |  |  |  |  |  |  |  |  |  |  |  |  |  |  |  |  |  |  |  |  |  |  |  |  |  |  |
| 1331.07000 |  | Fab & Install CHL Instrmenttn & Controls Labor FY10 | 778d | 2009-08-27 A | 2012-10-15 A | 12131.07015 FS-500d, 12131.07015b FS-500d, 9-090M | 100% |  |  |  | MECH ENG [141.55 h]; MECH TECH [141.55 h]; ELEC ENG [283.11 h]; ELEC TECH [2724.89 h]; SUPPLIES & MATERIALS | 172,096.11 | 151,511.85 |  |  |  |  | 0 | 167522.0147 | ARENIUS D | 1 | 1 | S | DANA A | NB |  | Notebook Entry for S | APP | 08-016 | 3317 | Install | 09-012 | 11-001 |  |  |  |  |  |  |  |  |  |  |
| 1331.07000a |  | Fab & Install CHL Instrmenttn & Controls Labor FY11 | 778d | 2009-08-27 A | 2012-10-15 A | 1331.07000 FS-425d | 100% |  |  |  | MECH ENG [178.45 h]; MECH TECH [178.45 h]; ELEC ENG [356.89 h]; ELEC TECH [3435.11 h]; SUPPLIES & MATERIALS | 217,779.24 | 191,002.16 |  |  |  |  | 0 | 217912.3919 | ARENIUS D | 1 | 1 | S | DANA A | NB |  | Notebook Entry for S | APP | 08-016 | 3317 | Install | 09-012 | 11-001 |  |  |  |  |  |  |  |  |  |  |
| 1331.07000b |  | Fab & Install CHL Instrmenttn & Controls Procurement | 778d | 2009-08-27 A | 2012-10-15 A | 12131.07015b FS-500d, 9-090M, 12131.07015 FS-500d | 100% |  |  |  | PROCUREMENT<$50K 60 NO ESCALATION FY11 | 576,862.28 |  | 0 | 576862.28308 | 57686228.308 | 100 | 0 | 576862.28308 | ARENIUS D | 1 | 1 | S | DANA A | NB |  | Notebook Entry for S | APP | 08-016 | 3317 | Install | 09-012 | 11-001 |  |  |  |  |  |  |  |  |  |  |
| 1331.07005 |  | Re-Baseline Actuals Adjustment | 1d | 2013-08-30 A | 2013-08-30 A |  | 100% | 2013-09-03 | 2013-09-03 |  | PROCUREMENT>$50K 69 NO ESCALATION | -33,687.42 |  |  |  |  | 100 |  |  |  |  |  |  |  |  | ADJ |  |  |  |  |  |  |  |  |  |  |  |  |  |  |  |  |  |
|  | 08 | **1.3.3.1.08 INSTRUMENT AIR & SUPPORT EQUIPMENT** |  | 2009-07-01 | 2013-08-30 |  |  |  |  |  |  |  |  |  |  |  |  |  |  |  |  |  |  |  |  |  |  |  |  |  |  |  |  |  |  |  |  |  |  |  |  |  |  |
| 1331.08000 |  | Proc & Install CHL Instrument Air Sys | 43d | 2009-07-01 A | 2009-08-31 A | 9-090M, 12131.08000 FS-500d | 100% |  |  |  | MECH DES [200 h]; MECH TECH [560 h]; PROCUREMENT<$50K 60; MECH ENG [120 h]; ELEC ENG [120 h]; ELEC TECH [240 h] | 96,041.85 | 56,425.6 | 0 | 39616.25 | 3961625 | 100 | 0 | 99695.85 | ARENIUS D | 1 | 1 | S | DANA A | NB |  | Notebook Entry for S |  |  |  | Install |  |  |  |  |  |  |  |  |  |  |  |  |
| 1331.08005 |  | Re-Baseline Actuals Adjustment | 1d | 2013-08-30 A | 2013-08-30 A |  | 100% | 2013-09-03 | 2013-09-03 |  | PROCUREMENT>$50K 69 NO ESCALATION | -30,541.46 |  |  |  |  | 100 |  |  |  |  |  |  |  |  | ADJ |  |  |  |  |  |  |  |  |  |  |  |  |  |  |  |  |  |
|  | 09 | **1.3.3.1.09 MOTOR CONTROL CENTERS** |  | 2009-07-01 | 2013-08-30 |  |  |  |  |  |  |  |  |  |  |  |  |  |  |  |  |  |  |  |  |  |  |  |  |  |  |  |  |  |  |  |  |  |  |  |  |  |  |
| 1331.09000 |  | Proc & Install Motor Control Centers | 221d | 2009-07-01 A | 2010-05-21 A | 12131.09000 FS-500d, 9-090M | 100% |  |  |  | SKLLD TRADE [360 h]; ELEC ENG [80 h]; ELEC DES [80 h]; PROCUREMENT<$50K 60; PROCUREMENT>$50K 69 | 254,267.06 | 20,225.79 | 0 | 234041.26619 | 23404126.619 | 100 | 0 | 254449.26619 | ARENIUS D | 1 | 1 | S | DANA A | NB |  | Notebook Entry for S |  |  |  | Install |  |  |  |  |  |  |  |  |  |  |  |  |
| 1331.09005 |  | Re-Baseline Actuals Adjustment | 1d | 2013-08-30 A | 2013-08-30 A |  | 100% | 2013-09-03 | 2013-09-03 |  | PROCUREMENT>$50K 69 NO ESCALATION | -16,549.16 |  |  |  |  | 100 |  |  |  |  |  |  |  |  | ADJ |  |  |  |  |  |  |  |  |  |  |  |  |  |  |  |  |  |
|  | 10 | **1.3.3.1.10 CHL INSTALLATION & DESIGN** |  | 2009-12-21 | 2013-09-30 |  |  |  |  |  |  |  |  |  |  |  |  |  |  |  |  |  |  |  |  |  |  |  |  |  |  |  |  |  |  |  |  |  |  |  |  |  |  |
| 1331.10000 |  | Proc & Install CHL Piping & Compnts Labor FY10 | 746d | 2009-12-21 A | 2012-12-17 A | 12131.04025, 12131.10010, 2-15M FS-250d | 100% | 2009-12-28 | 2012-12-21 |  | ELEC ENG [652.52 h]; ELEC DES [93.22 h]; ELEC TECH [1211.83 h]; MECH DES [186.43 h]; MECH TECH [4054.96 h]; SR STAFF [1491.48 h] | 451,088.77 | 450,950.74 |  |  |  |  | 0 | 433859.1919 | ARENIUS D | 1 | 1 | S | DANA A | ST |  |  |  | 08-016 |  | Install | 09-012 | 11-001 |  |  |  |  |  |  |  |  |  |  |
| 1331.1000a |  | Proc & Install CHL Piping & Compnts Labor FY11 | 746d | 2009-12-21 A | 2012-12-17 A | 12131.10010, 12131.04025, 2-15M FS-250d | 100% | 2009-12-28 | 2012-12-21 |  | ELEC TECH [868.17 h]; MECH DES [133.57 h]; MECH TECH [2905.04 h]; SR STAFF [1068.52 h]; ELEC ENG [467.48 h]; ELEC DES [66.78 h] | 323,167.56 | 323,068.7 |  |  |  |  | 0 | 320735.5399 | ARENIUS D | 1 | 1 | S | DANA A | ST |  |  |  | 08-016 |  | Install | 09-012 | 11-001 |  |  |  |  |  |  |  |  |  |  |
| 1331.1000b |  | Proc & Install CHL Piping & Compnts Labor Procurement | 746d | 2009-12-21 A | 2012-12-17 A | 12131.10010, 12131.04025, 2-15M FS-250d | 100% | 2009-12-28 | 2012-12-21 |  | PROCUREMENT>$50K 69 NO ESCALATION FY11; PROCUREMENT<$50K 60 NO ESCALATION FY11 | 465,884.97 |  | 0 | 465884.96717 | 46588496.717 | 100 | 0 | 465884.96717 | ARENIUS D | 1 | 1 | S | DANA A | ST |  |  |  | 08-016 |  | Install | 09-012 | 11-001 |  |  |  |  |  |  |  |  |  |  |
| 1331.1005 |  | Install CHL Cold Box Transfer Line to Linac Labor | 18d | 2013-02-11 A | 2013-08-30 A | 1331.1000a, 9-130M | 100% | 2013-05-06 | 2013-05-30 |  | PLABOR | 100,000 |  |  |  |  |  | 15000 | 100000 | ARENIUS D | 1 | 1 | S | DANA A | ST |  |  |  | 08-016 |  |  | 09-012 | 11-001 | 13-003 |  |  |  |  |  |  |  |  |  |
| 1331.1010 |  | Re-Baseline Actuals Adjustment | 1d | 2013-08-30 A | 2013-08-30 A |  | 100% | 2013-09-03 | 2013-09-03 |  | PROCUREMENT>$50K 69 NO ESCALATION | 1,664,342.45 |  | 0 | 1664342.45 | 166434245 | 100 |  | 1664342.45 |  |  |  |  |  |  | ADJ |  |  |  |  |  |  |  |  |  |  |  |  |  |  |  |  |  |
| 2331.1005 |  | Install CHL Cold Box Transfer Line to Linac Labor | 20d | 2013-09-03 A | 2013-09-30 A | 9-130M FS+228d | 100% | 2013-10-01 | 2013-10-28 | 8/5 M-F w/JLAB Holidays ReBaseline | PLABOR; PROCUREMENT<$50K 60 | 4,799.8 |  | 0 | 1733.8 | 173380 | 100 |  | 0 | ARENIUS D | 1 | 1 | H | DANA A |  |  |  |  | 08-016 |  |  | 09-012 | 11-001 | 13-003 | 2331.1005 | 4799.8 | PE | PE | PE | NO | 13-015 | PR | OB |

Notes:
- 1331.03000: Entry Criteria: Ext Pred: 1.2.1.3.1.5 / Steps: Receipt of Plates and Heads (done); Receipt of Pipe,Flanges,Hardware,o-rings and weld metal (done); Receipt of Body Flanges, perforated plate and filters (done); Receipt of Shipping Material,Nitrogen,paint and carbon vessel internals (done); JLabs acceptance of main oil carbon vessels (done); JLabs acceptance of Main oil coalescer (done); JLabs acceptance of hp compressor skid coalescer (done); JLabs acceptance of mp compressor skid coalescer (done); JLabs acceptance of lp compressor skid coalescer (done); Additional Hardware (done)
- 1331.06000: Entry Criteria: Ext Pred: / 1.2.1.3.1.6 / Explanation: 25% of Labor for Placing Order / 25% of Labor to Monitor LOE as 5% per / month PROCUREMENT?????? $79,112 / 50% of Labor Recieve and / Inspect / EXPENSES?????? $26,766 / Procurement and Expenses to be Handled as a "D" / labor / Total / 25% Labor / % Total / 5 % Labor / % total / August / September / October / November / December / January / February / March / April / May / June / July / August / $ 35,847.96 / $ 143,391.82 / $ 8,961.99 / 6.25% / $ 1,792.40 / 1.25% / 7.50% / 8.75% / 10.00% / 11.25% / 12.50% / 13.75% / 15.00% / 16.25% / 17.50% / 18.75% / 20.00% / 21.25% / 22.50%
- 1331.07000: Explanation: 25% of Labor for Placing Order / 25% of Labor to Monitor LOE as 5% per month / PROCUREMENT?????? $576,862 / 50% of Labor Recieve and / Inspect / EXPENSES?????? $46,533 / Procurement and Expenses to be Handled as a "D" / labor / Total / 25% Labor / % Total / 5 % Labor / % total / August / September / October / November / December / January / February / March / $ 138,906.28 / $ 926,041.87 / $ 34,726.57 / 3.75% / $ 6,945.31 / 0.75% / 3.75% / 4.50% / 5.25% / 6.00% / 6.75% / 7.50% / 8.25% / 9.00%
- 1331.07000a: Explanation: 25% of Labor for Placing Order / 25% of Labor to Monitor LOE as 5% per month / PROCUREMENT?????? $576,862 / 50% of Labor Recieve and / Inspect / EXPENSES?????? $46,533 / Procurement and Expenses to be Handled as a "D" / labor / Total / 25% Labor / % Total / 5 % Labor / % total / August / September / October / November / December / January / February / March / $ 138,906.28 / $ 926,041.87 / $ 34,726.57 / 3.75% / $ 6,945.31 / 0.75% / 3.75% / 4.50% / 5.25% / 6.00% / 6.75% / 7.50% / 8.25% / 9.00%
- 1331.07000b: Explanation: 25% of Labor for Placing Order / 25% of Labor to Monitor LOE as 5% per month / PROCUREMENT?????? $576,862 / 50% of Labor Recieve and / Inspect / EXPENSES?????? $46,533 / Procurement and Expenses to be Handled as a "D" / labor / Total / 25% Labor / % Total / 5 % Labor / % total / August / September / October / November / December / January / February / March / $ 138,906.28 / $ 926,041.87 / $ 34,726.57 / 3.75% / $ 6,945.31 / 0.75% / 3.75% / 4.50% / 5.25% / 6.00% / 6.75% / 7.50% / 8.25% / 9.00%
- 1331.08000: Explanation: 25% of Labor for Placing Order / 25% of Labor to Monitor LOE as 5% per month / 50% of Labor Recieve and Inspect
- 1331.09000: Explanation: 25% of Labor for Placing Order / 25% of Labor to Monitor LOE as 5% per / month / PROCUREMENT?????? / $234,00 / 50% of Labor Recieve and / Inspect / Procurement and Expenses to be Handled as a / "D" / labor / Total / 25% Labor / % Total / 5 % Labor / % total / August / September / October / November / December / January / February / March / $ 49,316.99 / $ 246,584.95 / $ 12,329.25 / 5.00% / $ 2,465.85 / 1.00% / 6% / 7% / 8% / 9% / 10% / 11% / 12% / 13%
- 1331.10000: Entry Criteria: Ext Pred: Building / BOD / Steps: Procure Interconnecting Piping Valves (done); Procure field installed SS and CS piping and components (done); Install Piping Trench Support System (done); Install Cooling Water Piping (done); Leak Check and Pressure Test Trench Cooling Water Piping (done); Install Gaseous Helium HP, MP, and LP Piping in Trench to Gas Management Rack/Oil Removal 1 of 3 (done); Leak Check and Pressure Test HP, MP, and LP Trench Piping/Gas Management/Oil Removal (done); Install Warm Helium Compressor Oil Balancing Piping (done); Leak Check and Pressure Test Oil Balancing Piping (done); Install Final Vendor Supplied Piping Spools to GHe compressors (done); Install Final Cooling Water Connections to Cooling Tower Piping System (done); Install instrument air piping connections to warm helium compressors (done); Piping System Cleanup and purification (done); Install HP, MP, and LP Piping Spools Connections from Oil Removal to 4.5K Cold Box (done); Install 3 atm GHe supply piping to 4.5K Cold Box manifold (done); Install 1 atm GHe Dirty Return Piping from 4.5K Cold Box manifold (done); Install instrument air piping connection to 4.5K Cold Box air header (done); Install supply and return cooling water connections to 4.5K Cold box (done); Install Bearing Gas Supply piping to 4.5K Cold Box (done); Perform 4.5K Cold Box piping leak check and pressure test (done); Perform 4.5K Cold Box piping cleaning and decontamination (done); Install Gaseous Helium HP, MP, and LP Piping in Trench to Gas Management Rack/Oil Removal 2 of 3 (done); Install Gaseous Helium HP, MP, and LP Piping in Trench to Gas Management Rack/Oil Removal 3 of 3 (done); Connect to compressors (done)
- 1331.1000a: Entry Criteria: Ext Pred: Building / BOD / Steps: Procure Interconnecting Piping Valves (done); Procure field installed SS and CS piping and components (done); Install Piping Trench Support System (done); Install Cooling Water Piping (done); Leak Check and Pressure Test Trench Cooling Water Piping (done); Install Gaseous Helium HP, MP, and LP Piping in Trench to Gas Management Rack/Oil Removal 1 of 3 (done); Leak Check and Pressure Test HP, MP, and LP Trench Piping/Gas Management/Oil Removal (done); Install Warm Helium Compressor Oil Balancing Piping (done); Leak Check and Pressure Test Oil Balancing Piping (done); Install Final Vendor Supplied Piping Spools to GHe compressors (done); Install Final Cooling Water Connections to Cooling Tower Piping System (done); Install instrument air piping connections to warm helium compressors (done); Piping System Cleanup and purification (done); Install HP, MP, and LP Piping Spools Connections from Oil Removal to 4.5K Cold Box (done); Install 3 atm GHe supply piping to 4.5K Cold Box manifold (done); Install 1 atm GHe Dirty Return Piping from 4.5K Cold Box manifold (done); Install instrument air piping connection to 4.5K Cold Box air header (done); Install supply and return cooling water connections to 4.5K Cold box (done); Install Bearing Gas Supply piping to 4.5K Cold Box (done); Perform 4.5K Cold Box piping leak check and pressure test (done); Perform 4.5K Cold Box piping cleaning and decontamination (done); Install Gaseous Helium HP, MP, and LP Piping in Trench to Gas Management Rack/Oil Removal 2 of 3 (done); Install Gaseous Helium HP, MP, and LP Piping in Trench to Gas Management Rack/Oil Removal 3 of 3 (done); Connect to compressors (done)
- 1331.1000b: Entry Criteria: Ext Pred: Building / BOD / Steps: Procure Interconnecting Piping Valves (done); Procure field installed SS and CS piping and components (done); Install Piping Trench Support System (done); Install Cooling Water Piping (done); Leak Check and Pressure Test Trench Cooling Water Piping (done); Install Gaseous Helium HP, MP, and LP Piping in Trench to Gas Management Rack/Oil Removal 1 of 3 (done); Leak Check and Pressure Test HP, MP, and LP Trench Piping/Gas Management/Oil Removal (done); Install Warm Helium Compressor Oil Balancing Piping (done); Leak Check and Pressure Test Oil Balancing Piping (done); Install Final Vendor Supplied Piping Spools to GHe compressors (done); Install Final Cooling Water Connections to Cooling Tower Piping System (done); Install instrument air piping connections to warm helium compressors (done); Piping System Cleanup and purification (done); Install HP, MP, and LP Piping Spools Connections from Oil Removal to 4.5K Cold Box (done); Install 3 atm GHe supply piping to 4.5K Cold Box manifold (done); Install 1 atm GHe Dirty Return Piping from 4.5K Cold Box manifold (done); Install instrument air piping connection to 4.5K Cold Box air header (done); Install supply and return cooling water connections to 4.5K Cold box (done); Install Bearing Gas Supply piping to 4.5K Cold Box (done); Perform 4.5K Cold Box piping leak check and pressure test (done); Perform 4.5K Cold Box piping cleaning and decontamination (done); Install Gaseous Helium HP, MP, and LP Piping in Trench to Gas Management Rack/Oil Removal 2 of 3 (done); Install Gaseous Helium HP, MP, and LP Piping in Trench to Gas Management Rack/Oil Removal 3 of 3 (done); Connect to compressors (done)
- 1331.1005: Entry Criteria: Ext Pred: Building / BOD / Steps: Cold Compressor Return Line (done); 4.5K Primary Supply Line (done); Shield Supply Line (done); Shield Return Line (done); Transport to Primary Supply Line (done); VN2 UBX to 2KCBX (done)
- 2331.1005: Entry Criteria: Ext Pred: Building / BOD

| ID | WBS | Activity | Duration | Start | Finish | Predecessors | Complete | Planned start | Planned finish | Resources | Cost | Actual cost | Calculated Remaining Total Cost | MONTHLY EV COST | RESP - Responsibility | STRT%COMP for CM EVM | FNSH%COMP for CM EVM | Advance Purchase Plan > 500K | EVMS Reporting Codes | CAM RESPONSIBLE | 12 GEV MAJOR PROCUREMENT CATAGORY | Activities with Steps | CR 12-018 | CR 12-029 | CR 12-032 | OPC Allison | MARCH!!! | Claimed Material Divider | ReBaseline Actuals Adjustment | Remaining Material Cost Based on % Compl | Claimed Material Cost Based on % Complet | Initial Claimed Material Calc | In Progress Procurements | CR 11-036 | Specification | CR 13-003 | CR 11-004 | CR 10-029 | CR 11-006 |
| --- | --- | --- | --- | --- | --- | --- | --- | --- | --- | --- | --- | --- | --- | --- | --- | --- | --- | --- | --- | --- | --- | --- | --- | --- | --- | --- | --- | --- | --- | --- | --- | --- | --- | --- | --- | --- | --- | --- | --- |
|  | 11 | **1.3.3.1.11 CHL COMMISSIONING** |  | 2011-10-03 | 2013-08-30 |  |  |  |  |  |  |  |  |  |  |  |  |  |  |  |  |  |  |  |  |  |  |  |  |  |  |  |  |  |  |  |  |  |  |
| 1331.11000 |  | Cmmssn CHL Helium Plant Original | 306d | 2011-10-03 A | 2013-02-28 A | 1621025, 12131.11010 | 100% | 2011-10-03 | 2012-12-31 | ELEC ENG [902.4 h]; MECH ENG [1353.6 h]; MECH TECH [902.4 h]; ELEC TECH [902.4 h] | 239,981.84 | 240,692.57 | 0 | 238513.344 | ARENIUS D | 1 | 1 | APP | S | DANA A | 33111 | ST | 12-018F | 12-029F | 12-032 | OPC A | XX |  |  |  |  |  |  |  |  |  |  |  |  |
| 1331.11005 |  | Re-Baseline Actuals Adjustment | 1d | 2013-08-30 A | 2013-08-30 A |  | 100% | 2013-09-03 | 2013-09-03 | PROCUREMENT>$50K 69 NO ESCALATION | -72,267.46 |  |  |  |  |  |  |  |  |  |  |  |  |  |  |  |  | 100 | ADJ |  |  |  |  |  |  |  |  |  |  |
|  | 12 | **1.3.3.1.12 LINAC TRANSFER LINE** |  | 2009-12-21 | 2013-08-30 |  |  |  |  |  |  |  |  |  |  |  |  |  |  |  |  |  |  |  |  |  |  |  |  |  |  |  |  |  |  |  |  |  |  |
| 1331.12000 |  | Fab Cold Box Transfer Line & U-Tubes | 838d | 2009-12-21 A | 2013-08-12 A | 1331.02010 FS-550d, 9-110M FS-250d, 1331.02000, 1331.02001 FS-250d | 100% | 2009-12-28 | 2013-05-10 | PROCUREMENT<$50K 60; SUPPLIES & MATERIALS; MECH DES [40 h]; MECH ENG [80 h]; MECH TECH [1320 h]; ELEC ENG [80 h]; ELEC TECH [240 h] | 517,729.71 | 81,287.19 | 103324.396 | 516621.98 | ARENIUS D | 1 | 1 |  | S | DANA A |  | ST |  |  |  | OPC A |  | 100 |  | 0 | 412716.51 | 41271651 | Split |  |  |  |  |  |  |
| 1331.12005 |  | Re-Baseline Actuals Adjustment | 1d | 2013-08-30 A | 2013-08-30 A |  | 100% | 2013-09-03 | 2013-09-03 | PROCUREMENT>$50K 69 NO ESCALATION | 244,786.39 |  |  | 244786.39 |  |  |  |  |  |  |  |  |  |  |  |  |  | 100 | ADJ | 0 | 244786.39 | 24478639 |  |  |  |  |  |  |  |
|  | 2 | **1.3.3.2 HALL D** |  | 2009-04-16 | 2013-08-30 |  |  |  |  |  |  |  |  |  |  |  |  |  |  |  |  |  |  |  |  |  |  |  |  |  |  |  |  |  |  |  |  |  |  |
|  | 1 | **1.3.3.2.1 CHL-HALL D TRANSFER LINE AND HEADER** |  | 2011-08-01 | 2013-08-30 |  |  |  |  |  |  |  |  |  |  |  |  |  |  |  |  |  |  |  |  |  |  |  |  |  |  |  |  |  |  |  |  |  |  |
| 13321015 |  | Eng Design Cryogenic Transfer Line FY11 | 44d | 2011-08-01 A | 2011-09-30 A | 9-110M FS+204d, 1562149 | 100% |  |  | SR STAFF [63.42 h]; ELEC DES [15.86 h]; MECH DES [317.12 h]; OFFICE [63.42 h]; PLABOR; ELEC ENG [47.57 h]; MECH ENG [285.41 h] | 65,953.21 | 46,925.91 | 0 | 65953.2103 | ARENIUS D | 1 | 1 |  | H | DANA A |  |  |  |  |  |  |  |  |  |  |  |  |  | 11-036 |  |  |  |  |  |
| 13321055 |  | Design Solenoid Distribution Can (Header) BIA | 179d | 2011-08-01 A | 2012-04-20 A | 9-110M FS+204d | 100% |  |  |  |  |  |  | 0 | ARENIUS D | 1 | 1 |  | Z | DANA A |  |  |  |  |  |  |  |  |  |  |  |  |  | 11-036 |  |  |  |  |  |
| 13321025 |  | Fabricate Cryogenic Transfer Line Labor FY11 | 21d | 2011-09-01 A | 2011-09-30 A | 13321020 FS-82d | 100% |  |  | SUPPLIES & MATERIALS; ELEC ENG [4.88 h]; MECH ENG [19.51 h]; SR STAFF [9.76 h]; MECH DES [9.76 h]; ELEC TECH [29.27 h]; MECH TECH [263.41 h] | 17,731.98 | 15,780.76 | 0 | 17731.9799 | ARENIUS D | 1 | 1 |  | H | DANA A |  |  |  |  |  |  |  |  |  |  |  |  |  | 11-036 |  |  |  |  |  |
| 13321035 |  | Fabricate Cryogenic Transfer Line Procurement | 259d | 2011-09-01 A | 2012-09-17 A | 13321030 FS-123d | 100% |  |  | PROCUREMENT<$50K 60 NO ESCALATION FY12; PROCUREMENT>$50K 69 NO ESCALATION FY12 | 109,000 |  | 0 | 109000 | ARENIUS D | 1 | 1 |  | D | DANA A |  |  |  |  |  |  |  | 100 |  | 0 | 109000 | 10900000 |  | 11-036 |  |  |  |  |  |
| 13321020 |  | Eng Design Cryogenic Transfer Line FY12 | 238d | 2011-10-03 A | 2012-09-17 A | 13321015 | 100% |  |  | ELEC ENG [72.43 h]; MECH ENG [434.59 h]; SR STAFF [96.58 h]; ELEC DES [24.14 h]; MECH DES [482.88 h]; OFFICE [96.58 h]; PLABOR | 103,631.86 | 73,734.65 | 0 | 103631.8616 | ARENIUS D | 1 | 1 |  | S | DANA A |  | ST |  |  |  |  |  |  |  |  |  |  |  | 11-036 |  |  |  |  |  |
| 13321030 |  | Fabricate Cryogenic Transfer Line Labor FY12 | 258d | 2011-10-03 A | 2012-10-15 A | 13321025 | 100% |  |  | SUPPLIES & MATERIALS; ELEC ENG [35.12 h]; MECH ENG [140.49 h]; SR STAFF [70.24 h]; MECH DES [70.24 h]; ELEC TECH [210.73 h]; MECH TECH [1896.59 h] | 131,890.39 | 117,393.45 | 0 | 131730.7213 | ARENIUS D | 1 | 1 |  | S | DANA A |  | ST |  |  |  |  |  |  |  |  |  |  |  | 11-036 | 1294025 |  |  |  |  |
| 13321065 |  | Fabricate Solenoid Distribution Can (Header) Procurement | 189d | 2011-11-14 A | 2012-08-20 A | 13321060 FS-154d | 100% |  |  | PROCUREMENT<$50K 60; PROCUREMENT>$50K 69 | 175,423 |  | 0 | 175423 | ARENIUS D | 1 | 1 |  | D | DANA A |  |  |  |  |  |  |  | 100 |  | 0 | 175423 | 17542300 |  | 11-036 |  |  |  |  |  |
| 13321060 |  | Fabricate Solenoid Distribution Can (Header) Labor | 162d | 2012-03-05 A | 2012-10-19 A | 9-120M, 13321055 FS-10d | 100% |  |  | ELEC ENG [520 h]; MECH ENG [960 h]; SR STAFF [80 h]; MECH DES [800 h]; SUPPLIES & MATERIALS; ELEC DES [280 h]; PLABOR | 350,718.84 | 166,215.12 | 0 | 350228.92 | ARENIUS D | 1 | 1 |  | S | DANA A |  | ST |  |  |  |  |  |  |  |  |  |  |  | 11-036 | 1294005 |  |  |  |  |
| 13321045 |  | Install Cryogenic Transfer Line Procurement | 55d | 2012-08-27 A | 2012-11-12 A | 13321035 FS-12d, 13321030 FS-30d | 100% |  |  | PROCUREMENT<$50K 60 | 27,861.3 |  | 0 | 27861.3 | ARENIUS D | 1 | 1 |  | D | DANA A |  |  |  |  |  | OPC A |  | 100 |  | 0 | 27861.3 | 2786130 |  | 11-036 |  |  |  |  |  |
| 13321040 |  | Install Cryogenic Transfer Line Labor | 36d | 2012-10-01 A | 2012-11-19 A | 13321030 FS-10d, 13321035 FS-12d | 100% |  |  | MECH DES [120 h]; ELEC TECH [200 h]; MECH TECH [960 h]; SUPPLIES & MATERIALS; ELEC DES [40 h]; ELEC ENG [80 h]; MECH ENG [240 h]; SR STAFF [160 h] | 130,892.1 | 103,030.8 | 0 | 127704.1 | ARENIUS D | 1 | 1 |  | H | DANA A |  |  |  |  |  | OPC A |  |  |  |  |  |  |  | 11-036 |  |  |  |  |  |
| 13321070 |  | Install Solenoid Distribution Can (Header) | 7d | 2012-10-19 A | 2012-10-29 A | 151155, 13321065 FS+27d | 100% |  |  | ELEC ENG [80 h]; MECH DES [120 h]; MECH ENG [720 h]; SR STAFF [80 h]; ELEC DES [240 h] | 85,726 | 85,726 | 0 | 83074 | ARENIUS D | 1 | 1 |  | H | DANA A |  |  |  |  |  |  |  |  |  |  |  |  |  | 11-036 |  |  |  |  |  |
| 13321042 |  | Install Hall D Solenoid External Warm/Vent Piping Labor | 18d | 2012-11-12 A | 2012-12-17 A | 13321040, 9-130M FS+28d | 100% | 2012-11-12 | 2012-12-07 | ELEC TECH [200 h]; MECH TECH [960 h]; SUPPLIES & MATERIALS; ELEC DES [40 h]; ELEC ENG [80 h]; MECH ENG [240 h]; SR STAFF [160 h]; MECH DES [120 h] | 130,892.1 | 103,030.8 | 0 | 130892.1 | ARENIUS D | 1 | 1 |  | H | DANA A |  |  |  |  |  |  |  |  |  |  |  |  |  |  |  | 13-003 |  |  |  |
| 13321050 |  | Commission Cryogenic Transfer Line | 6d | 2012-12-17 A | 2013-03-22 A | 13321040 FS-10d, 13321045, 13321042 | 100% | 2013-01-09 | 2013-01-16 | MECH DES [80 h]; ELEC TECH [80 h]; MECH TECH [360 h]; SUPPLIES & MATERIALS; ELEC ENG [40 h]; MECH ENG [120 h]; SR STAFF [40 h] | 44,516.8 | 40,389.2 | 0 | 43266.8 | ARENIUS D | 1 | 1 |  | H | DANA A |  |  |  |  |  | OPC A | XX |  |  |  |  |  |  | 11-036 |  |  |  |  |  |
| 13321075 |  | Re-Baseline Actuals Adjustment | 1d | 2013-08-30 A | 2013-08-30 A |  | 100% | 2013-09-03 | 2013-09-03 | PROCUREMENT>$50K 69 NO ESCALATION | -247,899.6 |  |  |  |  |  |  |  |  |  |  |  |  |  |  |  |  | 100 | ADJ |  |  |  |  |  |  |  |  |  |  |
|  | 2 | **1.3.3.2.2 HALL D COLD BOX** |  | 2009-04-16 | 2013-08-30 |  |  |  |  |  |  |  |  |  |  |  |  |  |  |  |  |  |  |  |  |  |  |  |  |  |  |  |  |  |  |  |  |  |  |
| 13322000 |  | Refurblish H-D Cold Box | 96d | 2009-04-16 A | 2009-08-31 A | 9-100M FS-125d, 121322000 | 100% |  |  | MECH TECH [200 h]; PROCUREMENT<$50K 60; SUPPLIES & MATERIALS; ELEC TECH [160 h] | 64,544.89 | 14,517.2 | 0 | 65007.698685 | ARENIUS D | 1 | 1 |  | H | DANA A |  |  |  |  |  |  |  | 100 |  | 0 | 43039.424229 | 4303942.4229 |  | 11-036 |  |  | 11-004 |  |  |
| 13322005 |  | Relocation of Helium Refrigerator Labor (Frozen by CR11-036) | 6d | 2011-08-01 A | 2011-08-08 A | 9-110M FS+163d | 100% |  |  | MECH TECH [583.11 h]; ELEC ENG [291.56 h]; MECH ENG [510.22 h]; PLABOR; SR STAFF [109.33 h]; SUPPLIES & MATERIALS; ELEC TECH [437.33 h] | 134,842.76 | 110,398.2 | 0 | 134842.7619 | ARENIUS D | 1 | 1 |  | H | DANA A |  |  |  |  |  |  |  |  |  |  |  |  |  | 11-036 |  |  | 11-004 | 10-029 | 11-006 |
| 13322006 |  | Reverse entry per CR11-036 | 5d | 2011-08-01 A | 2011-08-05 A | 9-110M FS+204d | 100% |  |  | ELEC TECH [-437.33 h]; MECH TECH [-583.11 h]; ELEC ENG [-291.56 h]; MECH ENG [-510.22 h]; PLABOR; SR STAFF [-109.33 h]; SUPPLIES & MATERIALS | -134,842.76 | -110,398.2 |  |  | ARENIUS D | 1 | 1 |  | H | DANA A |  |  |  |  |  |  |  |  |  |  |  |  |  | 11-036 |  |  | 11-004 | 10-029 | 11-006 |
| 13322007 |  | Relocation of Helium Refrigerator Labor (Revised by CR11-036) | 151d | 2011-10-03 A | 2012-05-14 A | 9-120M | 100% |  |  | SR STAFF [120 h]; SUPPLIES & MATERIALS; ELEC TECH [480 h]; MECH TECH [640 h]; ELEC ENG [320 h]; MECH ENG [560 h]; PLABOR | 152,715.66 | 125,030.4 | 0 | 152715.66 | ARENIUS D | 1 | 1 |  | S | DANA A |  | ST |  |  |  |  |  |  |  |  |  |  |  | 11-036 |  |  | 11-004 | 10-029 | 11-006 |
| 13322010 |  | Relocation of Helium Refrigerator Procurement | 99d | 2011-12-01 A | 2012-04-27 A | 9-120M | 100% |  |  | PROCUREMENT<$50K 60; PROCUREMENT>$50K 69 | 153,333.74 |  | 0 | 153333.74 | ARENIUS D | 1 | 1 |  | D | DANA A |  |  |  |  |  |  |  | 100 |  | 0 | 153333.74 | 15333374 |  | 11-036 |  |  | 11-004 | 10-029 | 11-006 |
| 13322015 |  | Re-Baseline Actuals Adjustment | 1d | 2013-08-30 A | 2013-08-30 A |  | 100% | 2013-09-03 | 2013-09-03 | PROCUREMENT>$50K 69 NO ESCALATION | -185,714.51 |  |  |  |  |  |  |  |  |  |  |  |  |  |  |  |  | 100 | ADJ |  |  |  |  |  |  |  |  |  |  |

Notes:
- 1331.11000: Entry Criteria: Ext Pred: Building / BOD / Steps: Gas Management System (done); Oil Removal Equipment (done); Warm Helium Compressor #1 (done); Warm Helium Compressor #2 (done); Warm Helium Compressor #3 (done); Warm Helium Compressor #4 (done); Warm Helium Compressor #5 (done)
- 1331.12000: Steps: Historic P (done); Fab u-tubes (done); Fabricate TL end cans (done); Fabricate Cold Box Transfer Line (25% completion) (done); Fabricate Cold Box Transfer Line (50% completion) (done); Fabricate Cold Box Transfer Line (75% completion) (done); Fabricate Cold Box Transfer LIne (100% completion) (done)
- 13321020: Steps: 3D Design Model (done); Design Details (done); Parts List (done); Vessel Specification (done); Design Approvals/Review (done)
- 13321030: Steps: Machine Parts Procurement (done); Piping Materials Procurement (done); Vacuum Shell Procurement (done); Valve Procurement (done); Detailed Piping Complete (done); Leak Checking (done)
- 13321060: Steps: Offload & stage vessles for assembly (done); Assemble shield circuit (done); Assembe vessels into insulating vacuum shell (done); Install valves & reliefs (done); Install interconnecting piping (done); Install vacuum insulation Blankets (done); Install Instrumentation (done); Pressure & Leak Check (done)
- 13322007: Steps: Work Plan Development (done); Remove Refrigerator (done); Place Refrigerator in new location (done); Relocate Compressors (done); Rigging (done)

| ID | WBS | Activity | Duration | Start | Finish | Predecessors | Complete | Planned start | Planned finish | Resources | Cost | Actual cost | Remaining Material Cost Based on % Compl | Claimed Material Cost Based on % Complet | Initial Claimed Material Calc | Claimed Material Divider | Calculated Remaining Total Cost | MONTHLY EV COST | RESP - Responsibility | STRT%COMP for CM EVM | FNSH%COMP for CM EVM | EVMS Reporting Codes | CAM RESPONSIBLE | Installation | CR 10-059 | CR 11-004 | CR 11-036 | Activities with Steps | CR 12-001 | ReBaseline Actuals Adjustment | CR 08-016 | CR 09-012 | Profile change | 12 GeV 2nd level Critical Path |
| --- | --- | --- | --- | --- | --- | --- | --- | --- | --- | --- | --- | --- | --- | --- | --- | --- | --- | --- | --- | --- | --- | --- | --- | --- | --- | --- | --- | --- | --- | --- | --- | --- | --- | --- |
|  | 3 | **1.3.3.2.3 HALL DISTRIBUTION SYSTEM** |  | 2009-09-13 | 2013-08-30 |  |  |  |  |  |  |  |  |  |  |  |  |  |  |  |  |  |  |  |  |  |  |  |  |  |  |  |  |  |
| 13323000 |  | Proc H-D Refrigerator Equip & Piping Proc | 481d | 2009-09-13 A | 2011-08-22 A | 121323000 FS-500d, 16332040F FS-500d, 13322000 FS-500d | 100% | 2009-09-14 | 2011-08-22 | PROCUREMENT<$50K 60 NO ESCALATION FY12; PROCUREMENT>$50K 69 NO ESCALATION FY12 | 300,049.39 |  | 0 | 300049.39 | 30004939 | 100 | 0 | 300048.74 | ARENIUS D | 1 | 1 | D | DANA A | Install | 10-059 | 11-004 | 11-036 |  |  |  |  |  |  |  |
| 13323005 |  | Proc & Install H-D Refrigerator Equip & Piping (Original labor Frozen per CR 11-036) | 6d | 2011-08-01 A | 2011-08-08 A | 16332040F, 121323000, 13322000 | 100% |  |  | MECH DES [65.85 h]; MECH TECH [1415.69 h]; ELEC ENG [98.77 h]; ELEC DES [98.77 h]; ELEC TECH [65.85 h]; SUPPLIES & MATERIALS; MECH ENG [98.77 h] | 89,111.73 | 85,164.15 |  |  |  |  | 0 | 89111.7364 | ARENIUS D | 1 | 1 | H | DANA A |  | 10-059 | 11-004 | 11-036 |  |  |  |  |  |  |  |
| 13323010 |  | Reverse Entry per CR 11-036) | 5d | 2011-08-01 A | 2011-08-05 A | 9-110M FS+204d | 100% |  |  | ELEC ENG [-98.77 h]; ELEC DES [-98.77 h]; ELEC TECH [-65.85 h]; SUPPLIES & MATERIALS; MECH ENG [-98.77 h]; MECH DES [-65.85 h]; MECH TECH [-1415.69 h] | -89,111.73 | -85,164.15 |  |  |  |  |  |  | ARENIUS D | 1 | 1 | H | DANA A |  | 10-059 | 11-004 | 11-036 |  |  |  |  |  |  |  |
| 13323015 |  | Install H-D Refrigerator Equip & Piping Labor (Revised per CR 11-036) FY11 | 298.5d | 2011-09-01 A | 2012-11-12 A | 9-110M FS+227d | 100% |  |  | ELEC DES [23.55 h]; ELEC TECH [15.7 h]; SUPPLIES & MATERIALS; MECH ENG [23.55 h]; MECH DES [15.7 h]; MECH TECH [337.57 h]; ELEC ENG [23.55 h] | 21,917.45 | 20,976.15 |  |  |  |  | 0 | 21248.1489 | ARENIUS D | 1 | 1 | S | DANA A |  | 10-059 | 11-004 | 11-036 | ST | 12-001 |  |  |  |  |  |
| 13323015a |  | Install H-D Refrigerator Equip & Piping Labor (Revised per CR 11-036) FY12 | 299d | 2011-09-01 A | 2012-11-12 A | 13323015 FS-90d | 100% |  |  | ELEC TECH [64.3 h]; SUPPLIES & MATERIALS; MECH ENG [96.45 h]; MECH DES [64.3 h]; MECH TECH [1382.43 h]; ELEC ENG [96.45 h]; ELEC DES [96.45 h] | 89,886.42 | 85,908.62 |  |  |  |  | 0 | 89788.1547 | ARENIUS D | 1 | 1 | S | DANA A |  | 10-059 | 11-004 | 11-036 | ST | 12-001 |  |  |  |  |  |
| 13323020 |  | Install H-D Refrigerator Equip & Piping Procurement (Revised per CR 11-036) | 279d | 2011-09-01 A | 2012-10-15 A | 13323015a FS-107d | 100% |  |  | PROCUREMENT>$50K 69 NO ESCALATION FY12 | 52,694.49 |  | 0 | 52694.49 | 5269449 | 100 | 0 | 52694.49 | ARENIUS D | 1 | 1 | D | DANA A |  | 10-059 | 11-004 | 11-036 |  |  |  |  |  |  |  |
| 13323025 |  | Re-Baseline Actuals Adjustment | 1d | 2013-08-30 A | 2013-08-30 A |  | 100% | 2013-09-03 | 2013-09-03 | PROCUREMENT>$50K 69 NO ESCALATION | -201,441.51 |  |  |  |  | 100 |  |  |  |  |  |  |  |  |  |  |  |  |  | ADJ |  |  |  |  |
|  | 4 | **1.3.3.2.4 INSTRUMENTATION & CONTROLS** |  | 2009-10-01 | 2013-08-30 |  |  |  |  |  |  |  |  |  |  |  |  |  |  |  |  |  |  |  |  |  |  |  |  |  |  |  |  |  |
| 13324000 |  | Install H-D Refrigerator Instrmenttn & Controls Procurement | 468d | 2009-10-01 A | 2011-08-22 A | 121324000 | 100% |  |  | PROCUREMENT<$50K 60 NO ESCALATION FY12 | 137,074.16 |  | 0 | 137074.16 | 13707416 | 100 | 0 | 137074.16 | ARENIUS D | 1 | 1 | U | DANA A | Install | 10-059 | 11-004 | 11-036 |  |  |  | 08-016 | 09-012 |  |  |
| 13324005 |  | Install H-D Refrigerator Instrmenttn & Controls Original Labor Frozen per CR 11-036 | 6d | 2011-08-01 A | 2011-08-08 A | 9-110M FS+60d, 121324000, 13326000 FS-52d | 100% |  |  | ELEC TECH [372.21 h]; SUPPLIES & MATERIALS; ELEC ENG [65.68 h] | 23,035.87 | 20,410.62 |  |  |  |  | 0 | 23035.8701 | ARENIUS D | 1 | 1 | H | DANA A |  | 10-059 | 11-004 | 11-036 |  |  |  | 08-016 | 09-012 |  |  |
| 13324010 |  | Reverse Entry Per CR 11-036 | 5d | 2011-08-01 A | 2011-08-05 A | 9-110M FS+204d | 100% |  |  | ELEC TECH [-372.21 h]; SUPPLIES & MATERIALS; ELEC ENG [-65.68 h] | -23,035.87 | -20,410.62 |  |  |  |  |  |  | ARENIUS D | 1 | 1 | H | DANA A |  | 10-059 | 11-004 | 11-036 |  |  |  | 08-016 | 09-012 |  |  |
| 13324015 |  | Install H-D Refrigerator Instrmenttn & Controls FY11 | 283.11d | 2011-09-01 A | 2012-10-22 A | 121324000, 13326010 FS-125d, 13326015 FS-141d, 9-110M FS+227d | 100% |  |  | ELEC TECH [114.24 h]; SUPPLIES & MATERIALS; ELEC ENG [20.16 h] | 7,265.88 | 6,460.13 |  |  |  |  | 0 | 7070.3356 | ARENIUS D | 1 | 1 | U | DANA A |  | 10-059 | 11-004 | 11-036 |  | 12-001 |  | 08-016 | 09-012 |  |  |
| 13324015a |  | Install H-D Refrigerator Instrmenttn & Controls FY12 | 284d | 2011-09-01 A | 2012-10-22 A | 13324015 FS-110d | 100% |  |  | ELEC TECH [565.76 h]; SUPPLIES & MATERIALS; ELEC ENG [99.84 h] | 36,113.98 | 31,996.31 |  |  |  |  | 0 | 36129.3692 | ARENIUS D | 1 | 1 | U | DANA A |  | 10-059 | 11-004 | 11-036 |  | 12-001 |  | 08-016 | 09-012 |  |  |
| 13324020 |  | Re-Baseline Actuals Adjustment | 1d | 2013-08-30 A | 2013-08-30 A |  | 100% | 2013-09-03 | 2013-09-03 | PROCUREMENT>$50K 69 NO ESCALATION | 277,907.69 |  | 0 | 277907.69 | 27790769 | 100 |  | 277907.69 |  |  |  |  |  |  |  |  |  |  |  | ADJ |  |  |  |  |
|  | 5 | **1.3.3.2.5 U-TUBES** |  | 2011-08-01 | 2013-08-30 |  |  |  |  |  |  |  |  |  |  |  |  |  |  |  |  |  |  |  |  |  |  |  |  |  |  |  |  |  |
| 13325000 |  | Fab Cryogenic U-Tubes (Frozen Per CR 11-036) | 6d | 2011-08-01 A | 2011-08-08 A | 13323000 FS-40d, 9-110M FS+125d, 13323015a FS-155d, 13323020 FS-159d, 121325000, 13323005 FS-40d | 100% |  |  | SUPPLIES & MATERIALS; MECH TECH [255 h] | 12,004.44 | 10,982.85 |  |  |  |  | 0 | 12004.44 | ARENIUS D | 1 | 1 | H | DANA A |  | 10-059 | 11-004 | 11-036 |  |  |  |  |  | C |  |
| 13325005 |  | Reverse Entry Per CR 11-036 | 5d | 2011-08-01 A | 2011-08-05 A | 9-110M FS+204d | 100% |  |  | MECH TECH [-255 h]; SUPPLIES & MATERIALS | -12,004.44 | -10,982.85 |  |  |  |  |  |  | ARENIUS D | 1 | 1 | H | DANA A |  | 10-059 | 11-004 | 11-036 |  |  |  |  |  | C |  |
| 13325010 |  | Fab Cryogenic U-Tubes Labor (Revised Per CR 11-036) | 127d | 2012-07-02 A | 2012-12-17 A | 13323015a FS-40d, 121325000, 13323005 FS-40d, 13323000 FS+0.5d, 13323020 FS-30d, 9-120M FS+105d, 9-110M FS+125d | 100% | 2012-07-02 | 2013-01-07 | MECH TECH [600 h]; SUPPLIES & MATERIALS | 29,567.06 | 27,053.9 |  |  |  |  | 0 | 29144.41 | ARENIUS D | 1 | 1 | H | DANA A |  | 10-059 | 11-004 | 11-036 |  |  |  |  |  | C |  |
| 13325015 |  | Fab Cryogenic U-Tubes Procurment (Revised Per CR 11-036) | 127d | 2012-07-02 A | 2012-12-17 A | 121325000, 9-110M FS+125d, 13323020 FS-30d, 13323005 FS-40d, 13323000 FS-119d, 13323015a FS-40d | 100% | 2012-07-02 | 2013-01-07 | PROCUREMENT<$50K 60 | 26,020.93 |  | 0 | 26020.93 | 2602093 | 100 | 0 | 26020.93 | ARENIUS D | 1 | 1 | D | DANA A |  | 10-059 | 11-004 | 11-036 |  |  |  |  |  | C |  |
| 13325020 |  | Re-Baseline Actuals Adjustment | 1d | 2013-08-30 A | 2013-08-30 A |  | 100% | 2013-09-03 | 2013-09-03 | PROCUREMENT>$50K 69 NO ESCALATION | -25,704.19 |  |  |  |  | 100 |  |  |  |  |  |  |  |  |  |  |  |  |  | ADJ |  |  |  |  |
|  | 6 | **1.3.3.2.6 FIELD INSTALLATION** |  | 2011-08-01 | 2013-08-30 |  |  |  |  |  |  |  |  |  |  |  |  |  |  |  |  |  |  |  |  |  |  |  |  |  |  |  |  |  |
| 13326000 |  | Install Field Compnts (Frozen Per CR 11-036) | 6d | 2011-08-01 A | 2011-08-08 A | 3C-09M, 13325015 FS-222d, 13325000 FS-100d, 9-120M, 9-110M FS+50d, 13325010 FS-222d | 100% |  |  | SKLLD TRADE [92 h]; ELEC ENG [122.67 h]; ELEC TECH [552 h]; MECH ENG [122.67 h]; MECH DES [30.67 h]; MECH TECH [1870.67 h]; SUPPLIES & MATERIALS | 146,483.56 | 125,316.72 |  |  |  |  | 0 | 146483.5536 | ARENIUS D | 1 | 1 | U | DANA A | Install | 10-059 | 11-004 | 11-036 |  |  |  | 08-016 | 09-012 |  | 2 |
| 13326005 |  | Reverse Entry Per CR 11-036 | 5d | 2011-08-01 A | 2011-08-05 A | 9-110M FS+204d | 100% |  |  | SUPPLIES & MATERIALS; MECH DES [-30.67 h]; SKLLD TRADE [-92 h]; MECH TECH [-1870.67 h]; MECH ENG [-122.67 h]; ELEC ENG [-122.67 h]; ELEC TECH [-552 h] | -146,483.56 | -125,316.72 |  |  |  |  |  |  | ARENIUS D | 1 | 1 | H | DANA A |  | 10-059 | 11-004 | 11-036 |  |  |  | 08-016 | 09-012 |  | 2 |
| 13326010 |  | Install Field Compnts Labor (Revised Per CR 11-036) | 238d | 2011-10-03 A | 2012-09-17 A | 3C-09M, 13322007 FS-79d, 9-110M FS+60d, 13325010 FS-86d, 13325015 FS-86d, 13322010 FS-98d | 100% |  |  | ELEC ENG [160 h]; ELEC TECH [720 h]; SUPPLIES & MATERIALS; MECH DES [40 h]; SKLLD TRADE [120 h]; MECH TECH [2440 h]; MECH ENG [160 h] | 197,146.44 | 168,656.8 |  |  |  |  | 0 | 197146.44 | ARENIUS D | 1 | 1 | U | DANA A |  | 10-059 | 11-004 | 11-036 |  |  |  | 08-016 | 09-012 |  | 2 |
| 13326015 |  | Install Field Compnts Procurement (Revised Per CR 11-036) | 238d | 2011-10-03 A | 2012-09-17 A | 3C-09M, 13325015 FS-86d, 13325010 FS-86d, 9-110M FS+60d | 100% |  |  | PROCUREMENT<$50K 60 | 40,880.01 |  | 0 | 40880.01 | 4088001 | 100 | 0 | 40880.01 | ARENIUS D | 1 | 1 | D | DANA A |  | 10-059 | 11-004 | 11-036 |  |  |  | 08-016 | 09-012 |  | 2 |
| 13326020 |  | Re-Baseline Actuals Adjustment | 1d | 2013-08-30 A | 2013-08-30 A |  | 100% | 2013-09-03 | 2013-09-03 | PROCUREMENT>$50K 69 NO ESCALATION | 216,504.83 |  | 0 | 216504.83 | 21650483 | 100 |  | 216504.83 |  |  |  |  |  |  |  |  |  |  |  | ADJ |  |  |  |  |

Notes:
- 13323000: Entry Criteria: Ext Pred: Building / BOD
- 13323005: Entry Criteria: Ext Pred: Building / BOD
- 13323010: Entry Criteria: Ext Pred: Building / BOD
- 13323015: Entry Criteria: Ext Pred: Building / BOD / Steps: Arrange Equipment Move (done); Set Refrigerator and Equipment in place (done); Install Interconnecting Piping (done); Install Electrical/Controls (done); Pre-ops Checkout (done)
- 13323015a: Entry Criteria: Ext Pred: Building / BOD / Steps: Arrange Equipment Move (done); Set Refrigerator and Equipment in place (done); Install Interconnecting Piping (done); Install Electrical/Controls (done); Pre-ops Checkout (done)
- 13323020: Entry Criteria: Ext Pred: Building / BOD
- 13324000: Entry Criteria: Ext Pred: Building / BOD
- 13324005: Entry Criteria: Ext Pred: Building / BOD
- 13324010: Entry Criteria: Ext Pred: Building / BOD
- 13324015: Entry Criteria: Ext Pred: Building / BOD
- 13324015a: Entry Criteria: Ext Pred: Building / BOD
- 13326000: Entry Criteria: Ext Pred: Building / BOD
- 13326005: Entry Criteria: Ext Pred: Building / BOD
- 13326010: Entry Criteria: Ext Pred: Building / BOD
- 13326015: Entry Criteria: Ext Pred: Building / BOD

| ID | WBS | Activity | Type | Duration | Start | Finish | Predecessors | Complete | Planned start | Planned finish | Resources | Cost | Actual cost | Remaining Material Cost Based on % Compl | Claimed Material Cost Based on % Complet | Initial Claimed Material Calc | Claimed Material Divider | Calculated Remaining Total Cost | MONTHLY EV COST | RESP - Responsibility | STRT%COMP for CM EVM | FNSH%COMP for CM EVM | 12 GeV 2nd level Critical Path | EVMS Reporting Codes | CAM RESPONSIBLE | CR 09-012 | CR 10-059 | CR 11-004 | CR 11-036 | MARCH!!! | ReBaseline Actuals Adjustment | LOE Divider | LOE Multiplier | CR 08-058 | CR 08-029 | CR 08-059 | CR 10-065 | CR 11-041 | CR 13-003 | CR 09-047 | CR 10-001 | Milestone Level | Advance Purchase Plan > 500K | CR 08-016 | CR 10-003 | CR 07-024 | 12 GEV MAJOR PROCUREMENT CATAGORY | CR 11-001 | CR 10-030 | CR 12-035 | Activities with Steps | Inter Project Link (IPL) | LOE % Pre Calc | LOE % |
| --- | --- | --- | --- | --- | --- | --- | --- | --- | --- | --- | --- | --- | --- | --- | --- | --- | --- | --- | --- | --- | --- | --- | --- | --- | --- | --- | --- | --- | --- | --- | --- | --- | --- | --- | --- | --- | --- | --- | --- | --- | --- | --- | --- | --- | --- | --- | --- | --- | --- | --- | --- | --- | --- | --- |
|  | 7 | **1.3.3.2.7 COMMISSIONING** |  |  | 2012-12-17 | 2013-08-30 |  |  |  |  |  |  |  |  |  |  |  |  |  |  |  |  |  |  |  |  |  |  |  |  |  |  |  |  |  |  |  |  |  |  |  |  |  |  |  |  |  |  |  |  |  |  |  |  |
| 13327000 |  | Cmmssn H-D Refrigerator Sys |  | 6d | 2012-12-17 A | 2013-02-18 A | 13324000, 16332010U FS-20d, 16332010, 9-130M FS+10d, 13326015 FS-5d, 13324015a, 13324005, 13326010 FS-5d, 13326000 | 100% | 2013-01-02 | 2013-01-09 | ELEC DES [120 h]; PROCUREMENT<$50K 60; ELEC ENG [320 h]; SUPPLIES & MATERIALS; MECH DES [120 h] | 82,588.15 | 35,518.8 | 0 | 40880.01 | 4088001 | 100 | 0 | 81490.15 | ARENIUS D | 1 | 1 | 2 | H | DANA A | 09-012 | 10-059 | 11-004 | 11-036 | XX |  |  |  |  |  |  |  |  |  |  |  |  |  |  |  |  |  |  |  |  |  |  |  |  |
| 13327005 |  | Re-Baseline Actuals Adjustment |  | 1d | 2013-08-30 A | 2013-08-30 A |  | 100% | 2013-09-03 | 2013-09-03 | PROCUREMENT>$50K 69 NO ESCALATION | -59,402.38 |  |  |  |  | 100 |  |  |  |  |  |  |  |  |  |  |  |  |  | ADJ |  |  |  |  |  |  |  |  |  |  |  |  |  |  |  |  |  |  |  |  |  |  |  |
|  | 4 | **1.3.4 BEAM TRANSPORT** |  |  | 2009-01-02 | 2013-12-12 |  |  |  |  |  |  |  |  |  |  |  |  |  |  |  |  |  |  |  |  |  |  |  |  |  |  |  |  |  |  |  |  |  |  |  |  |  |  |  |  |  |  |  |  |  |  |  |  |
|  | 1 | **1.3.4.1 SPREADERS & RECOMBINERS** |  |  | 2009-01-02 | 2013-12-12 |  |  |  |  |  |  |  |  |  |  |  |  |  |  |  |  |  |  |  |  |  |  |  |  |  |  |  |  |  |  |  |  |  |  |  |  |  |  |  |  |  |  |  |  |  |  |  |  |
|  | 1 | **1.3.4.1.1 DIPOLES** |  |  | 2009-01-02 | 2013-11-15 |  |  |  |  |  |  |  |  |  |  |  |  |  |  |  |  |  |  |  |  |  |  |  |  |  |  |  |  |  |  |  |  |  |  |  |  |  |  |  |  |  |  |  |  |  |  |  |  |
| 13411909LOE |  | FY09 Mngmnt & Oversight (S/R Dipoles) |  | 189d | 2009-01-02 A | 2009-09-30 A | 13411909LOEXD | 100% |  |  | SR STAFF [396.29 h]; TRAVEL | 62,981.29 | 40,754.46 |  |  |  |  | 0 | 62981.290349 | BEVINS M | 1 | 1 |  | E | MIKE B |  |  |  |  |  |  | 100 | 100 | 08-058 |  |  |  |  |  |  |  |  |  |  |  |  |  |  |  |  |  |  |  |  |
| 13411075 |  | Prcrmnt Prep of Septa (S/R Dipoles) |  | 161d | 2009-01-05 A | 2009-08-21 A | 9-090M FS+59d | 100% |  |  | MECH DES [60 h]; MECH ENG [160 h] | 12,840 | 12,840 |  |  |  |  | 0 | 12840 | BEVINS M | 1 | 1 |  | H | MIKE B |  |  |  |  |  |  |  |  |  | 08-029 | 08-059 | 10-065 | 11-041 | 13-003F |  |  |  |  |  |  |  |  |  |  |  |  |  |  |  |
| 13411095 |  | Prcrmnt Prep of Curved Dipoles (S/R Dipoles) |  | 185d | 2009-03-02 A | 2009-11-18 A | 9-090M FS+65d | 100% |  |  | MECH ENG [52 h]; MECH DES [44 h] | 5,278.8 | 5,278.8 |  |  |  |  | 0 | 5247.08 | BEVINS M | 1 | 1 |  | H | MIKE B |  |  |  |  |  |  |  |  |  | 08-029 |  |  |  |  |  |  |  |  |  |  |  |  |  |  |  |  |  |  |  |
| 13411115 |  | Prcrmnt Prep for C Dipoles & Coils (S/R Dipoles) |  | 156d | 2009-04-20 A | 2009-11-30 A | 9-090M FS+65d | 100% |  |  | MECH ENG [80 h]; MECH DES [72 h] | 8,330.66 | 8,330.66 |  |  |  |  | 0 | 8261.28 | BEVINS M | 1 | 1 |  | H | MIKE B |  |  |  |  |  |  |  |  |  | 08-029 |  |  |  |  |  |  |  |  |  |  |  |  |  |  |  |  |  |  |  |
| 13411085 |  | Vend Fab Septa (S/R Dipoles) LABOR INITIAL FY09 |  | 1d | 2009-08-03 A | 2009-08-03 A | 13411080M | 100% |  |  | MECH ENG [28 h]; MECH DES [11.6 h] | 2,295.22 | 2,295.22 |  |  |  |  | 0 | 2295.224 | BEVINS M | 1 | 1 |  | H | MIKE B | 09-012 |  |  |  |  |  |  |  |  | 08-029 | 08-059 | 10-065 | 11-041 | 13-003F | 09-047 |  |  |  |  |  |  |  |  |  |  |  |  |  |  |
| 13411086 |  | Vend Fab Septa (S/R Dipoles) LABOR FINAL FY09 |  | 42d | 2009-08-03 A | 2009-09-30 A | 13411085 | 100% |  |  | MECH ENG [67.2 h]; MECH DES [23.2 h] | 5,305.12 | 5,305.12 |  |  |  |  | 0 | 5305.12 | BEVINS M | 1 | 1 |  | H | MIKE B | 09-012 |  |  |  |  |  |  |  |  | 08-029 | 08-059 | 10-065 | 11-041 | 13-003F | 09-047 |  |  |  |  |  |  |  |  |  |  |  |  |  |  |
| 13411087 |  | Vend Fab Septa (S/R Dipoles) Materials |  | 160d | 2009-08-03 A | 2010-03-29 A | 9-090M FS+223d | 100% |  |  | PROCUREMENT<$50K 60 NO ESCALATION; PROCUREMENT>$50K 69 NO ESCALATION | 202,000 |  | 0 | 202000 | 20200000 | 100 | 0 | 202000 | BEVINS M | 1 | 1 |  | P | MIKE B | 09-012 |  |  |  |  |  |  |  |  | 08-029 | 08-059 | 10-065 | 11-041 | 13-003F | 09-047 | 10-001A |  |  |  |  |  |  |  |  |  |  |  |  |  |
| 13411087A |  | Vend Fab Septa (S/R Dipoles) First Article ZA Magnet |  | 466d | 2009-08-03 A | 2011-06-20 A | 13411087 FS-32d | 100% |  |  | PROCUREMENT>$50K 69 NO ESCALATION | 39,900 |  | 0 | 39900 | 3990000 | 100 | 0 | 39900 | BEVINS M | 1 | 1 |  | P | MIKE B | 09-012 |  |  |  |  |  |  |  |  | 08-029 | 08-059 | 10-065 | 11-041 |  | 09-047 | 10-001A |  |  |  |  |  |  |  |  |  |  |  |  |  |
| 13411087B |  | Vend Fab Septa (S/R Dipoles) Deliver (4) ZA Magnet Assemblies |  | 466d | 2009-08-03 A | 2011-06-20 A | 13411087A FS-145d | 100% |  |  | PROCUREMENT>$50K 69 NO ESCALATION | 159,600 |  | 0 | 159600 | 15960000 | 100 | 0 | 159600 | BEVINS M | 1 | 1 |  | P | MIKE B | 09-012 |  |  |  |  |  |  |  |  | 08-029 | 08-059 | 10-065 | 11-041 | 13-003F | 09-047 | 10-001A |  |  |  |  |  |  |  |  |  |  |  |  |  |
| 13411087C |  | Vend Fab Septa (S/R Dipoles) Deliver (3) ZA Magnet Assemblies |  | 466d | 2009-08-03 A | 2011-06-20 A | 13411087B FS-275d | 100% |  |  | PROCUREMENT>$50K 69 NO ESCALATION | 150,000 |  | 0 | 150000 | 15000000 | 100 | 0 | 150000 | BEVINS M | 1 | 1 |  | P | MIKE B | 09-012 |  |  |  |  |  |  |  |  | 08-029 | 08-059 | 10-065 | 11-041 | 13-003F | 09-047 | 10-001A |  |  |  |  |  |  |  |  |  |  |  |  |  |
| 13411087D |  | Vend Fab Septa (S/R Dipoles) Deliver ZA Spare Coil Set (Frozen by CR 11-041) |  | 466d | 2009-08-03 A | 2011-06-20 A | 13411087C FS-338d | 100% |  |  | PROCUREMENT>$50K 69 NO ESCALATION | 23,800 |  | 0 | 23800 | 2380000 | 100 | 0 | 23800 | BEVINS M | 1 | 1 |  | P | MIKE B | 09-012 |  |  |  |  |  |  |  |  | 08-029 | 08-059 | 10-065 | 11-041 | 13-003F | 09-047 | 10-001A |  |  |  |  |  |  |  |  |  |  |  |  |  |
| 13411087D10 |  | Vend Fab Septa (S/R Dipoles) Deliver (2) YA Magnet Assemblies (Frozen by CR 11-041) |  | 466d | 2009-08-03 A | 2011-06-20 A | 13411087D FS-338d | 100% |  |  | PROCUREMENT>$50K 69 NO ESCALATION | 68,850 |  | 0 | 68850 | 6885000 | 100 | 0 | 68850 | BEVINS M | 1 | 1 |  | P | MIKE B | 09-012 |  |  |  |  |  |  |  |  | 08-029 | 08-059 | 10-065 | 11-041 | 13-003F | 09-047 | 10-001A |  |  |  |  |  |  |  |  |  |  |  |  |  |
| 13411087D5 |  | Vend Fab Septa (S/R Dipoles) Deliver (2) ZB Coil Sets (Frozen by CR 11-041) |  | 466d | 2009-08-03 A | 2011-06-20 A | 9-090M FS+223d | 100% |  |  | PROCUREMENT>$50K 69 NO ESCALATION | 51,000 |  | 0 | 51000 | 5100000 | 100 | 0 | 51000 | BEVINS M | 1 | 1 |  | P | MIKE B | 09-012 |  |  |  |  |  |  |  |  | 08-029 | 08-059 | 10-065 | 11-041 | 13-003F | 09-047 | 10-001A |  |  |  |  |  |  |  |  |  |  |  |  |  |
| 13411080M |  | Award Contract for Septa (S/R DIPOLES) | milestone | 0d | 2009-08-26 A | 2009-08-26 A | 13411075, 121416010 FS-100d, 121411110M FS-100d | 100% | 2009-09-30 | 2009-09-30 |  |  |  |  |  |  |  |  | 0 | BEVINS M | 1 | 1 |  | M | MIKE B |  |  |  |  |  |  |  |  |  | 08-029 | 08-059 | 10-065 | 11-041 | 13-003F | 09-047 |  | 6 |  |  |  |  |  |  |  |  |  |  |  |  |
| 13411055 |  | Prcrmnt Prep for H Steel (S/R Dipoles) |  | 90d | 2009-09-08 A | 2010-01-22 A | 9-100M FS+2d | 100% |  |  | MECH DES [60 h]; MECH ENG [80 h] | 7,935.7 | 7,935.7 |  |  |  |  | 0 | 7982.4 | BEVINS M | 1 | 1 |  | H | MIKE B |  |  |  |  |  |  |  |  |  | 08-029 |  |  |  |  |  |  |  |  |  |  |  |  |  |  |  |  |  |  |  |
| 13411086ALOE |  | Vend Fab Septa (S/R Dipoles) LABOR FY10 |  | 248d | 2009-10-01 A | 2010-09-30 A | 13411086 | 100% |  |  | MECH DES [135.6 h]; MECH ENG [397.2 h] | 32,290.16 | 32,290.16 |  |  |  |  | 0 | 32290.164 | BEVINS M | 1 | 1 |  | E | MIKE B | 09-012 |  |  |  |  |  | 100 | 100 |  | 08-029 | 08-059 | 10-065 | 11-041 | 13-003F | 09-047 |  |  |  |  |  |  |  |  |  |  |  |  |  |  |
| 13411910LOE |  | FY10 Mngmnt & Oversight (S/R Dipoles) |  | 248d | 2009-10-01 A | 2010-09-30 A | 13411909LOE, 121411909LOE | 100% |  |  | TRAVEL; SR STAFF [520 h] | 85,344.06 | 55,182.4 |  |  |  |  | 0 | 85344.063075 | BEVINS M | 1 | 1 |  | E | MIKE B |  |  |  |  |  |  | 100 | 100 |  |  |  |  |  |  |  |  |  |  |  |  |  |  |  |  |  |  |  |  |  |
| 13411100M |  | Award Contract for Curved Dipoles (S/R DIPOLES) | milestone | 0d | 2009-11-18 A | 2009-11-18 A | 121411110M FS-24d, 121416010, 13411095 | 100% | 2010-01-05 | 2010-01-05 |  |  |  |  |  |  |  |  | 0 | BEVINS M | 1 | 1 |  | M | MIKE B |  |  |  |  |  |  |  |  |  | 08-029 |  |  |  |  |  |  | 6 |  |  |  |  |  |  |  |  |  |  |  |  |
| 13411105 |  | P-1 Vend Fab Curved Dipoles (S/R Dipoles) Labor FY09 |  | 214d | 2009-11-18 A | 2010-09-30 A | 13411100M | 100% |  |  | MECH ENG [28.74 h]; MECH DES [12.77 h] | 2,470.24 | 2,470.24 |  |  |  |  | 0 | 2393.7362 | BEVINS M | 1 | 1 |  | H | MIKE B | 09-012 |  |  |  |  |  |  |  |  | 08-029 |  |  |  |  |  | 10-001B |  | APP | 08-016 |  |  |  |  |  |  |  |  |  |  |
| 13411105b |  | P-1 Vend Fab Curved Dipoles (S/R Dipoles) Labor FY10 |  | 214d | 2009-11-18 A | 2010-09-30 A | 13411105 FS-400d | 100% |  |  | MECH ENG [79.26 h]; MECH DES [35.23 h] | 6,813.08 | 6,813.08 |  |  |  |  | 0 | 6813.0762 | BEVINS M | 1 | 1 |  | H | MIKE B |  |  |  |  |  |  |  |  |  |  |  |  |  |  |  | 10-001B |  | APP |  |  |  |  |  |  |  |  |  |  |  |
| 13411105c |  | Vend Fab Curved Dipoles Peg Point #1 Receipt of Coil Materials and Tooling |  | 148d | 2009-11-18 A | 2010-06-28 A | 9-100M FS+34d, 13411100M | 100% |  |  | PROCUREMENT<$50K 60 NO ESCALATION; PROCUREMENT>$50K 69 NO ESCALATION | 234,292.65 |  | 0 | 234292.65 | 23429265 | 100 | 0 | 234292.65 | BEVINS M | 1 | 1 |  | P | MIKE B |  |  |  |  |  |  |  |  |  |  |  | 10-065 |  |  |  | 10-001B |  | APP |  | 10-003 |  |  |  |  |  |  |  |  |  |
| 13411105d |  | Vend Fab Curved Dipoles Peg Point #2 Receipt of Core Materials |  | 148d | 2009-11-18 A | 2010-06-28 A | 13411105c FS-63d | 100% |  |  | PROCUREMENT>$50K 69 NO ESCALATION | 263,857.99 |  | 0 | 263857.99 | 26385799 | 100 | 0 | 263857.99 | BEVINS M | 1 | 1 |  | P | MIKE B |  |  |  |  |  |  |  |  |  |  |  | 10-065 |  |  |  |  |  | APP |  | 10-003 |  |  |  |  |  |  |  |  |  |
| 13411105f |  | Vend Fab Curved Dipoles Peg Point #3 JLab Approval of First Article XU Coil |  | 162d | 2009-11-18 A | 2010-07-19 A | 13411105d FS-63d | 100% |  |  | PROCUREMENT>$50K 69 NO ESCALATION | 20,800 |  | 0 | 20800 | 2080000 | 100 | 0 | 20800 | BEVINS M | 1 | 1 |  | P | MIKE B |  |  |  |  |  |  |  |  |  |  |  | 10-065 |  |  |  |  |  | APP |  | 10-003 |  |  |  |  |  |  |  |  |  |
| 13411105g |  | Vend Fab Curved Dipoles Peg Point #4 JLab Approval of First Article XU Core Assembly |  | 162d | 2009-11-18 A | 2010-07-19 A | 13411105f FS-108d | 100% |  |  | PROCUREMENT>$50K 69 NO ESCALATION | 13,978.67 |  | 0 | 13978.67 | 1397867 | 100 | 0 | 13978.67 | BEVINS M | 1 | 1 |  | P | MIKE B |  |  |  |  |  |  |  |  |  |  |  | 10-065 |  |  |  |  |  | APP |  | 10-003 |  |  |  |  |  |  |  |  |  |
| 13411105h |  | Vend Fab Curved Dipoles Peg Point #5 Receipt and Acceptance of XU Coils by JLab |  | 246d | 2009-11-18 A | 2010-11-15 A | 13411105g FS-150d | 100% |  |  | PROCUREMENT>$50K 69 NO ESCALATION | 62,400 |  | 0 | 62400 | 6240000 | 100 | 0 | 62400 | BEVINS M | 1 | 1 |  | P | MIKE B |  |  |  |  |  |  |  |  |  |  |  | 10-065 |  |  |  |  |  | APP |  | 10-003 |  |  |  |  |  |  |  |  |  |
| 13411105j |  | Vend Fab Curved Dipoles Peg Point #6 Receipt and Acceptance of XU Magnet Assemblies by JLab |  | 246d | 2009-11-18 A | 2010-11-15 A | 13411105h FS-150d | 100% |  |  | PROCUREMENT>$50K 69 NO ESCALATION | 27,957.33 |  | 0 | 27957.33 | 2795733 | 100 | 0 | 27957.33 | BEVINS M | 1 | 1 |  | P | MIKE B |  |  |  |  |  |  |  |  |  |  |  | 10-065 |  |  |  |  |  | APP |  | 10-003 |  |  |  |  |  |  |  |  |  |
| 13411105k |  | Vend Fab Curved Dipoles Peg Point #7 Receipt and Acceptance of XM Coils by JLab |  | 311d | 2009-11-18 A | 2011-03-01 A | 13411105j FS-193d | 100% | 2009-11-18 | 2011-02-28 | PROCUREMENT>$50K 69 NO ESCALATION | 47,000 |  | 0 | 47000 | 4700000 | 100 | 0 | 47000 | BEVINS M | 1 | 1 |  | P | MIKE B |  |  |  |  |  |  |  |  |  |  |  | 10-065 |  |  |  |  |  | APP |  | 10-003 |  |  |  |  |  |  |  |  |  |
| 13411105n |  | Vend Fab Curved Dipoles Peg Point #8 Receipt and Acceptance of XV Coils by JLab |  | 312d | 2009-11-18 A | 2011-03-01 A | 13411105k FS-214d | 100% |  |  | PROCUREMENT>$50K 69 NO ESCALATION | 64,426.65 |  | 0 | 64426.65 | 6442665 | 100 | 0 | 64426.65 | BEVINS M | 1 | 1 |  | P | MIKE B |  |  |  |  |  |  |  |  |  |  |  | 10-065 |  |  |  |  |  | APP |  | 10-003 |  |  |  |  |  |  |  |  |  |
| 13411105o |  | Vend Fab Curved Dipoles Peg Point #9 Receipt and Acceptance of XV Magnet Assemblies by JLab |  | 326d | 2009-11-18 A | 2011-03-21 A | 13411105n FS-235d | 100% |  |  | PROCUREMENT>$50K 69 NO ESCALATION | 44,115.99 |  | 0 | 44115.99 | 4411599 | 100 | 0 | 44115.99 | BEVINS M | 1 | 1 |  | P | MIKE B |  |  |  |  |  |  |  |  |  |  |  | 10-065 |  |  |  |  |  | APP |  | 10-003 |  |  |  |  |  |  |  |  |  |
| 13411105p |  | Vend Fab Curved Dipoles Peg Point #10 Receipt and Acceptance of BP Coils by JLab |  | 390d | 2009-11-18 A | 2011-06-20 A | 13411105o FS-235d | 100% |  |  | PROCUREMENT>$50K 69 NO ESCALATION | 69,626.69 |  | 0 | 69626.69 | 6962669 | 100 | 0 | 69626.69 | BEVINS M | 1 | 1 |  | D | MIKE B |  |  |  |  |  |  |  |  |  |  |  | 10-065 |  |  |  |  |  | APP |  | 10-003 |  |  |  |  |  |  |  |  |  |
| 13411105q |  | Vend Fab Curved Dipoles Peg Point #11 Receipt and Acceptance of JF Coils by JLab |  | 511d | 2009-11-18 A | 2011-12-12 A | 13411105p FS-235d | 100% |  |  | PROCUREMENT>$50K 69 NO ESCALATION | 9,600 |  | 0 | 9600 | 960000 | 100 | 0 | 9600 | BEVINS M | 1 | 1 |  | P | MIKE B |  |  |  |  |  |  |  |  |  |  |  | 10-065 |  |  |  |  |  | APP |  | 10-003 |  |  |  |  |  |  |  |  |  |
| 13411105r |  | Vend Fab Curved Dipoles Peg Point #12 Receipt and Acceptance of XM Magnet Assemblies by JLab |  | 311d | 2009-11-18 A | 2011-03-01 A | 13411105q FS-255d | 100% | 2009-11-18 | 2011-02-28 | PROCUREMENT>$50K 69 NO ESCALATION | 28,344 |  | 0 | 28344 | 2834400 | 100 | 0 | 28344 | BEVINS M | 1 | 1 |  | P | MIKE B |  |  |  |  |  |  |  |  |  |  |  | 10-065 |  |  |  |  |  | APP |  | 10-003 |  |  |  |  |  |  |  |  |  |
| 13411105s |  | Vend Fab Curved Dipoles Peg Point #13 Receipt and Acceptance of XX Coils by JLab |  | 429d | 2009-11-18 A | 2011-08-15 A | 13411105r FS-255d | 100% |  |  | PROCUREMENT>$50K 69 NO ESCALATION | 62,666.68 |  | 0 | 62666.68 | 6266668 | 100 | 0 | 62666.68 | BEVINS M | 1 | 1 |  | P | MIKE B |  |  |  |  |  |  |  |  |  |  |  | 10-065 |  |  |  |  |  | APP |  | 10-003 |  |  |  |  |  |  |  |  |  |
| 13411105t |  | Vend Fab Curved Dipoles Peg Point #14 Receipt and Acceptance of JG Magnet Assemblies by JLab |  | 390d | 2009-11-18 A | 2011-06-20 A | 13411105s FS-272d | 100% |  |  | PROCUREMENT>$50K 69 NO ESCALATION | 42,368 |  | 0 | 42368 | 4236800 | 100 | 0 | 42368 | BEVINS M | 1 | 1 |  | D | MIKE B |  |  |  |  |  |  |  |  |  |  |  | 10-065 |  |  |  |  |  | APP |  | 10-003 |  |  |  |  |  |  |  |  |  |
| 13411105u |  | Vend Fab Curved Dipoles Peg Point #15 Receipt and Acceptance of JH Magnet Assemblies by JLab |  | 390d | 2009-11-18 A | 2011-06-20 A | 13411105t FS-311d | 100% |  |  | PROCUREMENT>$50K 69 NO ESCALATION | 31,776 |  | 0 | 31776 | 3177600 | 100 | 0 | 31776 | BEVINS M | 1 | 1 |  | P | MIKE B |  |  |  |  |  |  |  |  |  |  |  | 10-065 |  |  |  |  |  | APP |  | 10-003 |  |  |  |  |  |  |  |  |  |
| 13411105v |  | Vend Fab Curved Dipoles Peg Point #16 Receipt and Acceptance of XX Magnet Assemblies by JLab |  | 429d | 2009-11-18 A | 2011-08-15 A | 13411105u FS-376d | 100% |  |  | PROCUREMENT>$50K 69 NO ESCALATION | 31,635.99 |  | 0 | 31635.99 | 3163599 | 100 | 0 | 31635.99 | BEVINS M | 1 | 1 |  | P | MIKE B |  |  |  |  |  |  |  |  |  |  |  | 10-065 |  |  |  |  |  | APP |  | 10-003 |  |  |  |  |  |  |  |  |  |
| 13411125 |  | P-1 Vend Fab C Dipoles & Coils (S/R Dipoles) Labor FY09 |  | 214d | 2009-11-18 A | 2010-09-30 A | 13411120M | 100% |  |  | MECH DES [23.42 h]; MECH ENG [55.35 h] | 4,704.32 | 4,704.32 |  |  |  |  | 0 | 4558.6163 | BEVINS M | 1 | 1 |  | H | MIKE B | 09-012 |  |  |  |  |  |  |  |  | 08-029 |  |  |  |  |  | 10-001B |  | APP | 08-016 |  | 07-024 | 3411B |  |  |  |  |  |  |  |
| 13411125b |  | P-1 Vend Fab C Dipoles & Coils (S/R Dipoles) Labor FY10 |  | 214d | 2009-11-18 A | 2010-09-30 A | 13411125 FS-200d | 100% |  |  | MECH DES [64.58 h]; MECH ENG [152.65 h] | 12,973.6 | 12,973.6 |  |  |  |  | 0 | 12973.6017 | BEVINS M | 1 | 1 |  | H | MIKE B |  |  |  |  |  |  |  |  |  |  |  |  |  |  |  | 10-001B |  | APP |  |  |  | 3411B |  |  |  |  |  |  |  |
| 13411120M |  | Award Contract for C Dipoles & Coils (S/R DIPOLES) | milestone | 0d | 2009-11-30 A | 2009-11-30 A | 13411115, 121416010 FS-20d | 100% | 2010-01-05 | 2010-01-05 |  |  |  |  |  |  |  |  | 0 | BEVINS M | 1 | 1 |  | M | MIKE B |  |  |  |  |  |  |  |  |  | 08-029 |  |  |  |  |  |  | 6 |  |  |  |  |  |  |  |  |  |  |  |  |
| 13411060M |  | Award Contract for H Steel (S/R DIPOLES) | milestone | 0d | 2010-01-22 A | 2010-01-22 A | 13411055, 121416010, 121411110M | 100% | 2010-02-24 | 2010-02-24 |  |  |  |  |  |  |  |  | 0 | BEVINS M | 1 | 1 |  | M | MIKE B |  |  |  |  |  |  |  |  |  |  |  |  |  |  |  |  | 6 |  |  |  |  |  |  |  |  |  |  |  |  |
| 13411106 |  | P-2 Vend Fab Curved Dipoles (S/R Dipoles) Original Labor FY10 |  | 247.4d | 2010-01-29 A | 2011-01-28 A | 9-100M FS+60d, 13411105c FS-400d, 13411105b FS-400d | 100% |  |  | MECH DES [27.58 h]; MECH ENG [68.95 h] | 5,845.05 | 5,845.05 |  |  |  |  | 0 | 5788.0767 | BEVINS M | 1 | 1 |  | E | MIKE B | 09-012 |  |  |  |  |  | 100 | 100 |  | 08-029 |  |  |  |  |  |  |  | APP | 08-016 | 10-003 |  |  | 11-001 |  |  |  |  |  |  |
| 13411106a |  | P-2 Vend Fab Curved Dipoles (S/R Dipoles) Original Labor FY11 |  | 248d | 2010-01-29 A | 2011-01-28 A | 13411105c FS-400d, 13411105b FS-400d, 9-100M FS+60d | 100% |  |  | MECH DES [12.42 h]; MECH ENG [31.05 h] | 2,632.32 | 2,632.32 |  |  |  |  | 0 | 2689.6131 | BEVINS M | 1 | 1 |  | E | MIKE B | 09-012 |  |  |  |  |  | 100 | 100 |  | 08-029 |  |  |  |  |  |  |  | APP | 08-016 | 10-003 |  |  | 11-001 |  |  |  |  |  |  |
| 13411126 |  | P-2 Vend Fab C Dipoles & Coils (S/R Dipoles) Original Labor FY10 |  | 248d | 2010-01-29 A | 2011-01-28 A | 13411125b FS-125d | 100% |  |  | MECH ENG [137.9 h]; MECH DES [55.16 h] | 11,690.73 | 11,690.73 |  |  |  |  | 0 | 11576.1534 | BEVINS M | 1 | 1 |  | E | MIKE B | 09-012 |  |  |  |  |  | 100 | 100 |  | 08-029 |  |  |  |  |  |  |  | APP | 08-016 | 10-003 | 07-024 | 3411B | 11-001 |  |  |  |  |  |  |
| 13411126a |  | P-2 Vend Fab C Dipoles & Coils (S/R Dipoles) Original Labor FY11 |  | 248d | 2010-01-29 A | 2011-01-28 A | 13411125b FS-125d | 100% |  |  | MECH ENG [62.1 h]; MECH DES [24.84 h] | 5,264.65 | 5,264.65 |  |  |  |  | 0 | 5379.2262 | BEVINS M | 1 | 1 |  | E | MIKE B | 09-012 |  |  |  |  |  | 100 | 100 |  | 08-029 |  |  |  |  |  |  |  | APP | 08-016 | 10-003 | 07-024 | 3411B | 11-001 |  |  |  |  |  |  |
| 13411065 |  | P-1 Vend Fab H Steel (S/R Dipoles) Labor FY10 |  | 394.57d | 2010-03-22 A | 2011-10-17 A | 13411060M | 100% |  |  | MECH ENG [10.97 h]; MECH DES [21.94 h] | 1,752.26 | 1,752.26 |  |  |  |  | 0 | 1714.9401 | BEVINS M | 1 | 1 |  | D | MIKE B | 09-012 |  |  |  |  |  |  |  |  | 08-029 |  |  |  |  |  |  |  | APP | 08-016 |  |  |  | 11-001 |  |  |  |  |  |  |
| 13411065a |  | P-1 Vend Fab H Steel (S/R Dipoles) Labor FY11 |  | 394.71d | 2010-03-22 A | 2011-10-17 A | 13411060M | 100% |  |  | MECH ENG [9.03 h]; MECH DES [18.06 h] | 1,442.4 | 1,442.4 |  |  |  |  | 0 | 1456.6293 | BEVINS M | 1 | 1 |  | D | MIKE B | 09-012 |  |  |  |  |  |  |  |  | 08-029 |  |  |  |  |  |  |  | APP | 08-016 |  |  |  | 11-001 |  |  |  |  |  |  |
| 13411065b |  | P-1 Vend Fab H Steel (S/R Dipoles) Procurement |  | 346d | 2010-03-22 A | 2011-08-08 A | 13411060M | 100% |  |  | PROCUREMENT>$50K 69 NO ESCALATION FY11 | 56,435.33 |  | 0 | 56435.33333 | 5643533.333 | 100 | 0 | 56435.33333 | BEVINS M | 1 | 1 |  | D | MIKE B | 09-012 |  |  |  |  |  |  |  |  | 08-029 |  |  |  |  |  |  |  | APP | 08-016 |  |  |  | 11-001 |  |  |  |  |  |  |
| 13411136 |  | Proc Prep BCOMM and Additional Steel FY10 |  | 114d | 2010-03-22 A | 2010-08-30 A | 9-100M | 100% |  |  | MECH ENG [385.4 h]; MECH DES [444.7 h] | 45,496.82 | 45,496.82 |  |  |  |  | 0 | 45496.818 | BEVINS M | 1 | 1 |  | H | MIKE B |  |  |  |  |  |  |  |  |  |  |  | 10-065 |  |  |  |  |  | APP |  |  |  |  |  | 10-030 | 12-035F |  |  |  |  |
| 13411160 |  | Proc Prep Extra Coils FY10 |  | 84d | 2010-03-29 A | 2010-07-26 A | 9-100M | 100% |  |  | MECH ENG [29.7 h]; MECH DES [59.5 h] | 4,647.53 | 4,647.53 |  |  |  |  | 0 | 4647.525 | BEVINS M | 1 | 1 |  | H | MIKE B |  |  |  |  |  |  |  |  |  |  |  | 10-065 |  |  |  |  |  | APP |  |  |  |  |  | 10-030 | 12-035F |  |  |  |  |
| 13411105w |  | Vend Fab Curved Dipoles Peg Point #17 Additional Material for XH and XY Magnets |  | 17d | 2010-07-01 A | 2010-07-26 A | 9-100M FS+184d | 100% |  |  | PROCUREMENT<$50K 60 NO ESCALATION | 43,316 |  | 0 | 43316 | 4331600 | 100 | 0 | 43316 | BEVINS M | 1 | 1 |  | P | MIKE B |  |  |  |  |  |  |  |  |  |  |  | 10-065 |  |  |  |  |  | APP |  |  |  |  |  |  |  |  |  |  |  |
| 13411165 |  | Proc Prep Extra Coils FY11 |  | 17d | 2010-07-01 A | 2010-07-26 A | 13411160 | 100% |  |  | MECH DES [20.5 h]; MECH ENG [10.3 h] | 1,605.68 | 1,605.68 |  |  |  |  | 0 | 1656.825 | BEVINS M | 1 | 1 |  | H | MIKE B |  |  |  |  |  |  |  |  |  |  |  | 10-065 |  |  |  |  |  | APP |  |  |  |  |  | 10-030 | 12-035F |  |  |  |  |
| 13411200 |  | Spreader Recombiner Dipole Refurb and Mod Documentation FY10 |  | 136.11d | 2010-07-01 A | 2011-01-24 A | 9-100M FS+184d | 100% |  |  | MECH DES [1363.93 h]; MECH ENG [629.51 h] | 104,898.36 | 105,057.82 |  |  |  |  | 0 | 103157.4267 | BEVINS M | 1 | 1 |  | S | MIKE B |  |  |  |  |  |  |  |  |  |  |  | 10-065 |  |  |  |  |  | APP |  |  |  |  | 11-001 |  |  | ST |  |  |  |
| 13411200a |  | Spreader Recombiner Dipole Refurb and Mod Documentation FY11 |  | 137d | 2010-07-01 A | 2011-01-24 A | 9-100M FS+184d, 13411200 | 100% |  |  | MECH ENG [570.49 h]; MECH DES [1236.07 h] | 95,073.37 | 95,073.37 |  |  |  |  | 0 | 96464.5431 | BEVINS M | 1 | 1 |  | S | MIKE B |  |  |  |  |  |  |  |  |  |  |  | 10-065 |  |  |  |  |  | APP |  |  |  |  | 11-001 |  |  | ST |  |  |  |
| 13411087F |  | Vend Fab Septa (S/R Dipoles) Material Annealing |  | 60d | 2010-08-02 A | 2010-10-25 A | 9-100M FS+204d | 100% |  |  | PROCUREMENT>$50K 69 NO ESCALATION; PROCUREMENT<$50K 60 NO ESCALATION | 75,000 |  | 0 | 75000 | 7500000 | 100 | 0 | 75000 | BEVINS M | 1 | 1 |  | D | MIKE B |  |  |  |  |  |  |  |  |  |  |  | 10-065 | 11-041 | 13-003F |  |  |  | APP |  |  |  | 3411A |  |  |  |  |  |  |  |
| 13411105x |  | Vend Fab Curved Dipoles Peg Point #18 Receipt and Acceptance XH and XY Magnets |  | 258d | 2010-08-02 A | 2011-08-15 A | 13411105w | 100% |  |  | PROCUREMENT>$50K 69 NO ESCALATION; PROCUREMENT<$50K 60 NO ESCALATION | 92,000 |  | 0 | 92000 | 9200000 | 100 | 0 | 92000 | BEVINS M | 1 | 1 |  | P | MIKE B |  |  |  |  |  |  |  |  |  |  |  | 10-065 |  |  |  |  |  | APP |  |  |  |  |  |  |  |  |  |  |  |
| 13411170M |  | Award Vend Fab Extra Coils | milestone | 0d | 2010-08-30 A | 2010-08-30 A | 13411165 | 100% | 2010-09-01 | 2010-09-01 |  |  |  |  |  |  |  |  | 0 | BEVINS M | 1 | 1 |  | M | MIKE B |  |  |  |  |  |  |  |  |  |  |  | 10-065 |  |  |  |  | 6 |  |  |  |  |  |  | 10-030 | 12-035F |  | IPL |  |  |
| 13411175 |  | Vend Fab Extra Coils Oversight |  | 207d | 2010-08-30 A | 2011-06-30 A | 13411170M | 100% |  |  | MECH DES [40 h]; MECH ENG [560 h] | 39,782.13 | 39,782.13 |  |  |  |  | 0 | 39919.2 | BEVINS M | 1 | 1 |  | S | MIKE B |  |  |  |  |  |  |  |  |  |  |  | 10-065 |  |  |  |  |  | APP |  |  |  |  |  | 10-030 | 12-035F | ST |  |  |  |
| 13411180 |  | Vend Fab Extra Coils 1st Article |  | 130d | 2010-08-30 A | 2011-03-14 A | 13411170M | 100% |  |  |  |  |  |  |  |  |  |  | 0 | BEVINS M | 1 | 1 |  | P | MIKE B |  |  |  |  |  |  |  |  |  |  |  | 10-065 |  |  |  |  |  | APP |  |  |  |  |  | 10-030 | 12-035F |  |  |  |  |
| 13411185 |  | Vend Fab Extra Coils Production (18) |  | 199d | 2010-08-30 A | 2011-06-20 A | 13411180 FS-76d | 100% |  |  | PROCUREMENT<$50K 60 | 46,435.5 |  | 0 | 46435.5 | 4643550 | 100 | 0 | 46435.5 | BEVINS M | 1 | 1 |  | D | MIKE B |  |  |  |  |  |  |  |  |  |  |  | 10-065 |  |  |  |  |  | APP |  |  |  |  |  | 10-030 | 12-035F |  |  |  |  |
| 13411066 |  | P-2 Vend Fab H Steel (S/R Dipoles) |  | 279d | 2010-09-02 A | 2011-10-17 A | 13411065a FS-95d, 13411065 FS-95d, 13411065b FS-95d | 100% |  |  | PROCUREMENT>$50K 69; MECH ENG [20 h] | 67,284.82 | 1,357.7 | 0 | 65927.12 | 6592712 | 100 | 0 | 67286.12 | BEVINS M | 1 | 1 |  | D | MIKE B |  |  |  |  |  |  |  |  |  | 08-029 |  |  |  |  |  |  |  | APP | 08-016 |  |  |  |  |  |  |  |  |  |  |
| 13411136a |  | Proc Prep BCOMM and Additional Steel FY11 |  | 14d | 2010-09-13 A | 2010-09-30 A | 13411136 | 100% |  |  | MECH DES [155.3 h]; MECH ENG [134.6 h] | 15,889.18 | 15,889.18 |  |  |  |  | 0 | 16395.474 | BEVINS M | 1 | 1 |  | H | MIKE B |  |  |  |  |  |  |  |  |  |  |  | 10-065 |  |  |  |  |  | APP |  |  |  |  |  | 10-030 | 12-035F |  |  |  |  |
| 13411108M |  | Deliver First Curved Dipoles (S/R Dipoles) | milestone | 0d | 2010-09-27 A | 2010-09-27 A | 13411105g, 13411100M | 100% | 2010-10-01 | 2010-10-01 |  |  |  |  |  |  |  |  | 0 | BEVINS M | 1 | 1 |  | M | MIKE B |  |  |  |  |  |  |  |  |  | 08-029 |  |  |  |  |  |  |  |  |  | 10-003 |  |  |  |  |  |  |  |  |  |
| 13411086BLOE |  | Vend Fab Septa (S/R Dipoles) LABOR FY11 |  | 165d | 2010-10-01 A | 2011-06-03 A | 13411086ALOE | 100% |  |  | MECH DES [93.6 h]; MECH ENG [267.6 h] | 22,552.67 | 22,552.67 |  |  |  |  | 0 | 22552.668 | BEVINS M | 1 | 1 |  | E | MIKE B | 09-012 |  |  |  |  |  | 100 | 100 |  | 08-029 | 08-059 | 10-065 | 11-041 | 13-003F | 09-047 |  |  |  |  |  |  |  |  |  |  |  |  | 1.81818181 | 98.18181818 |
| 13411911LOE |  | FY11 Mngmnt & Oversight (S/R Dipoles) |  | 248d | 2010-10-01 A | 2011-09-30 A | 13411910LOE | 100% |  |  | SR STAFF [280 h] | 30,662.8 | 30,662.8 |  |  |  |  | 0 | 30662.8 | BEVINS M | 1 | 1 |  | E | MIKE B |  |  |  |  |  |  | 100 | 100 |  |  |  |  |  |  |  |  |  |  |  |  |  |  |  |  |  |  |  | 8.46774193 | 91.53225806 |

Notes:
- 13411125: Corrective Actions: THIS WAS INCREASED TO FIX AN ERROR / WHICH WE SAW DURING THE CR07-024 WHICH WAS A DOUBLE ENTRY
- 13411125b: Corrective Actions: THIS WAS INCREASED TO FIX AN ERROR / WHICH WE SAW DURING THE CR07-024 WHICH WAS A DOUBLE ENTRY
- 13411126: Corrective Actions: THIS WAS INCREASED TO FIX AN ERROR / WHICH WE SAW DURING THE CR07-024 WHICH WAS A DOUBLE ENTRY
- 13411126a: Corrective Actions: THIS WAS INCREASED TO FIX AN ERROR / WHICH WE SAW DURING THE CR07-024 WHICH WAS A DOUBLE ENTRY
- 13411200: Steps: East Spreader (done); East Recombiner (done); West Spreader (done); West Recombiner (done); Transport Recombiner (done)
- 13411200a: Steps: East Spreader (done); East Recombiner (done); West Spreader (done); West Recombiner (done); Transport Recombiner (done)
- 13411170M: Explanation: IPL from 6 GeV BIA 534213060 and / 534213120
- 13411175: Steps: Phase 1 (done); Phase 2 (done)

| ID | Activity | Type | Duration | Start | Finish | Predecessors | Complete | Remaining | Planned start | Planned finish | Total float | Free float | Calendar | Resources | Cost | Actual cost | Calculated Remaining Total Cost | MONTHLY EV COST | RESP - Responsibility | STRT%COMP for CM EVM | FNSH%COMP for CM EVM | EVMS Reporting Codes | CAM RESPONSIBLE | CR 08-029 | CR 10-003 | CR 10-065 | CR 12-001 | Milestone Level | Inter Project Link (IPL) | CR 10-030 | CR 12-035 | Advance Purchase Plan > 500K | Remaining Material Cost Based on % Compl | Claimed Material Cost Based on % Complet | Initial Claimed Material Calc | Claimed Material Divider | Activities with Steps | CR 11-057 | 12 GEV MAJOR PROCUREMENT CATAGORY | CR 11-041 | CR 13-003 | Phil Dev | MARCH!!! | OPC Allison | CR 09-047 | CR 10-001 | LOE % Pre Calc | LOE % | LOE Divider | LOE Multiplier | CR 08-016 | CR 09-012 | CR 09-034 | CR 11-001 | CR 12-008 | CR 08-059 | H activities to change code | ReBaseline Actuals Adjustment | BOE NOTES | Original Activity ID Rebaseline | PRIOR MONTH EV COST | BOE Procurement | CR 13-015 | Post Rebaseline | Obligated Prior to Rebaseline | BOE Labor | Temple/Lehman | CR 14-001 |
| --- | --- | --- | --- | --- | --- | --- | --- | --- | --- | --- | --- | --- | --- | --- | --- | --- | --- | --- | --- | --- | --- | --- | --- | --- | --- | --- | --- | --- | --- | --- | --- | --- | --- | --- | --- | --- | --- | --- | --- | --- | --- | --- | --- | --- | --- | --- | --- | --- | --- | --- | --- | --- | --- | --- | --- | --- | --- | --- | --- | --- | --- | --- | --- | --- | --- | --- | --- | --- |
| 13411140 | Mag Measurment of New C & Curved Dipoles (S/R Dipoles) FY11 |  | 310.71d | 2011-01-17 A | 2012-04-16 A | 13411130M FS-250d, 13411110M FS-250d, 13411105v FS-200d, 13411105x FS-200d | 100% |  | 2011-01-18 | 2012-04-16 |  |  |  | MECH ENG [56 h]; MECH TECH [84.8 h] | 7,557.53 | 7,557.53 | 0 | 7457.536 | BEVINS M | 1 | 1 | H | MIKE B | 08-029 | 10-003 | 10-065 | 12-001 |  |  |  |  |  |  |  |  |  |  |  |  |  |  |  |  |  |  |  |  |  |  |  |  |  |  |  |  |  |  |  |  |  |  |  |  |  |  |  |  |  |
| 13411140a | Mag Measurment of New C & Curved Dipoles (S/R Dipoles) FY12 |  | 311d | 2011-01-17 A | 2012-04-16 A | 13411140 FS-110d | 100% |  | 2011-01-18 | 2012-04-16 |  |  |  | MECH TECH [339.2 h]; MECH ENG [224 h] | 30,230.64 | 30,230.64 | 0 | 30780.928 | BEVINS M | 1 | 1 | H | MIKE B | 08-029 | 10-003 | 10-065 | 12-001 |  |  |  |  |  |  |  |  |  |  |  |  |  |  |  |  |  |  |  |  |  |  |  |  |  |  |  |  |  |  |  |  |  |  |  |  |  |  |  |  |  |
| 13411136M | Award Vend Fab BCOMM and Additional Steel | milestone | 0d | 2011-02-01 A | 2011-02-01 A | 13411136a FS+60d | 100% |  | 2011-03-01 | 2011-03-01 |  |  |  |  |  |  |  | 0 | BEVINS M | 1 | 1 | M | MIKE B |  |  | 10-065 |  | 6 | IPL | 10-030 | 12-035F |  |  |  |  |  |  |  |  |  |  |  |  |  |  |  |  |  |  |  |  |  |  |  |  |  |  |  |  |  |  |  |  |  |  |  |  |  |
| 13411137 | Vend Fab BCOMM and Additional Steel Oversight |  | 257d | 2011-02-01 A | 2012-02-13 A | 13411136M | 100% |  |  |  |  |  |  | MECH ENG [200 h] | 13,736.92 | 13,867.37 | 0 | 13590 | BEVINS M | 1 | 1 | H | MIKE B |  |  | 10-065 |  |  |  | 10-030 | 12-035F | APP |  |  |  |  |  |  |  |  |  |  |  |  |  |  |  |  |  |  |  |  |  |  |  |  |  |  |  |  |  |  |  |  |  |  |  |  |
| 13411138 | Vend Fab BCOMM and Additional Steel (Materials) |  | 148d | 2011-02-01 A | 2011-08-30 A | 13411136M | 100% |  |  |  |  |  |  | PROCUREMENT<$50K 60; PROCUREMENT>$50K 69 | 95,000 |  | 0 | 95000 | BEVINS M | 1 | 1 | S | MIKE B |  |  | 10-065 |  |  |  | 10-030 | 12-035F | APP | 0 | 95000 | 9500000 | 100 | ST | 11-057 |  |  |  |  |  |  |  |  |  |  |  |  |  |  |  |  |  |  |  |  |  |  |  |  |  |  |  |  |  |  |
| 13411138a | Vend Fab BCOMM and Additional Steel (Machining) |  | 257d | 2011-02-01 A | 2012-02-13 A | 13411138 FS-163d | 100% |  |  |  |  |  |  | PROCUREMENT<$50K 60; PROCUREMENT>$50K 69 | 168,173.9 |  | 0 | 168173.9 | BEVINS M | 1 | 1 | S | MIKE B |  |  | 10-065 |  |  |  |  | 12-035F | APP | 0 | 168173.9 | 16817390 | 100 | ST | 11-057 |  |  |  |  |  |  |  |  |  |  |  |  |  |  |  |  |  |  |  |  |  |  |  |  |  |  |  |  |  |  |
| 13411190 | Receive and Inspect Extra Coils |  | 108d | 2011-03-01 A | 2011-08-01 A | 13411180 FS-20d, 13411185 FS-107d | 100% |  |  |  |  |  |  | MECH ENG [120 h]; MECH TECH [200 h]; COMP SCIENT [40 h] | 19,311.6 | 19,311.6 | 0 | 19311.6 | BEVINS M | 1 | 1 | H | MIKE B |  |  | 10-065 |  |  |  | 10-030 | 12-035F | APP |  |  |  |  |  |  |  |  |  |  |  |  |  |  |  |  |  |  |  |  |  |  |  |  |  |  |  |  |  |  |  |  |  |  |  |  |
| 13411087G | Vend Fab Septa (S/R Dipoles) Peg Point #1 Receipt of Material |  | 110d | 2011-03-29 A | 2011-08-31 A | 9-110M FS+117d | 100% |  |  |  |  |  |  | PROCUREMENT>$50K 69 NO ESCALATION; PROCUREMENT<$50K 60 NO ESCALATION | 74,750 |  | 0 | 74750 | BEVINS M | 1 | 1 | D | MIKE B |  |  | 10-065 |  |  |  |  |  | APP | 0 | 74750 | 7475000 | 100 |  |  | 3411A | 11-041 | 13-003F |  |  |  |  |  |  |  |  |  |  |  |  |  |  |  |  |  |  |  |  |  |  |  |  |  |  |  |
| 13411087H | Vend Fab Septa (S/R Dipoles) Peg Point #2 Acceptance and Shipping of First Article ZA Magnet Assembly |  | 389d | 2011-03-29 A | 2012-10-15 A | 13411087G FS-110d | 100% |  |  |  |  |  |  | PROCUREMENT>$50K 69 NO ESCALATION | 55,250 |  | 0 | 55250 | BEVINS M | 1 | 1 | D | MIKE B |  |  | 10-065 |  |  |  |  |  | APP | 0 | 55250 | 5525000 | 100 |  |  | 3411A | 11-041 | 13-003F | MP |  |  |  |  |  |  |  |  |  |  |  |  |  |  |  |  |  |  |  |  |  |  |  |  |  |  |
| 13411087J | Vend Fab Septa (S/R Dipoles) Peg Point #3 Delivery and Acceptance of Quantity 4 ZA Magnet Assemblies |  | 439d | 2011-03-29 A | 2013-02-11 A | 13411087H FS-172d | 100% |  | 2011-03-29 | 2013-01-03 |  |  |  | PROCUREMENT>$50K 69 NO ESCALATION | 170,000 |  | 0 | 170000 | BEVINS M | 1 | 1 | D | MIKE B |  |  | 10-065 |  |  |  |  |  | APP | 0 | 170000 | 17000000 | 100 |  |  | 3411A | 11-041 | 13-003F | MP | XX |  |  |  |  |  |  |  |  |  |  |  |  |  |  |  |  |  |  |  |  |  |  |  |  |  |
| 13411087K | Vend Fab Septa (S/R Dipoles) Peg Point #4 Delivery and Acceptance of Quantity 3 ZA Magnet Assemblies |  | 439d | 2011-03-29 A | 2013-06-17 A | 13411087J FS-188d | 100% |  | 2011-03-29 | 2013-01-03 |  |  |  | PROCUREMENT>$50K 69 NO ESCALATION | 127,500 |  | 0 | 127500 | BEVINS M | 1 | 1 | D | MIKE B |  |  | 10-065 |  |  |  |  |  | APP | 0 | 127500 | 12750000 | 100 |  |  | 3411A | 11-041 | 13-003F | MP | XX |  |  |  |  |  |  |  |  |  |  |  |  |  |  |  |  |  |  |  |  |  |  |  |  |  |
| 13411087N | Vend Fab Septa (S/R Dipoles) Peg Point #5 Delivery and Acceptance of ZA Spare Coil Set |  | 476d | 2011-03-29 A | 2013-08-30 A | 13411087K FS-209d | 100% |  | 2011-03-29 | 2013-02-27 |  |  |  | PROCUREMENT>$50K 69 NO ESCALATION | 21,500 |  | 21500 | 21500 | BEVINS M | 1 | 1 | D | MIKE B |  |  | 10-065 |  |  |  |  |  | APP | 0 | 21500 | 2150000 | 100 |  |  | 3411A | 11-041 | 13-003F | MP | XX | OPC A |  |  |  |  |  |  |  |  |  |  |  |  |  |  |  |  |  |  |  |  |  |  |  |  |
| 13411087P | Vend Fab Septa (S/R Dipoles) Peg Point #6 Delivery and Acceptance of Quantity 2 YA Magnet Assemblies |  | 476d | 2011-03-29 A | 2013-06-17 A | 13411087N FS-209d | 100% |  | 2011-03-29 | 2013-02-27 |  |  |  | PROCUREMENT>$50K 69 NO ESCALATION | 79,000 |  | 0 | 79000 | BEVINS M | 1 | 1 | D | MIKE B |  |  | 10-065 |  |  |  |  |  | APP | 0 | 79000 | 7900000 | 100 |  |  | 3411A | 11-041 | 13-003F | MP | XX | OPC A |  |  |  |  |  |  |  |  |  |  |  |  |  |  |  |  |  |  |  |  |  |  |  |  |
| 13411087Q | Vend Fab Septa (S/R Dipoles) Peg Point #7 Delivery and Acceptance of Quantity 2 ZB Coil Sets |  | 476d | 2011-03-29 A | 2013-08-30 A | 13411087P FS-229d | 100% |  | 2011-03-29 | 2013-02-27 |  |  |  | PROCUREMENT>$50K 69 NO ESCALATION | 69,000 |  | 34500 | 69000 | BEVINS M | 1 | 1 | D | MIKE B |  |  | 10-065 |  |  |  |  |  | APP | 0 | 69000 | 6900000 | 100 |  |  | 3411A | 11-041 | 13-003F | MP | XX | OPC A |  |  |  |  |  |  |  |  |  |  |  |  |  |  |  |  |  |  |  |  |  |  |  |  |
| 13411087C5 | Vend Fab Septa (S/R Dipoles) Deliver (3) ZA Magnet Assemblies (WANG Additional Cost to Terminate) |  | 14d | 2011-06-01 A | 2011-06-20 A | 9-110M FS+162d | 100% |  |  |  |  |  |  | PROCUREMENT>$50K 69 NO ESCALATION | -127,534 |  |  |  | BEVINS M | 1 | 1 | P | MIKE B |  |  | 10-065 |  |  |  |  |  | APP |  |  |  | 100 |  |  | 3411A | 11-041 | 13-003F |  |  |  | 09-047 | 10-001A |  |  |  |  |  |  |  |  |  |  |  |  |  |  |  |  |  |  |  |  |  |  |
| 13411087D05 | Vend Fab Septa (S/R Dipoles) Deliver ZA Spare Coil Set (Reverse Entry per CR 11-041) |  | 14d | 2011-06-01 A | 2011-06-20 A | 9-110M FS+162d | 100% |  |  |  |  |  |  | PROCUREMENT>$50K 69 NO ESCALATION | -23,800 |  |  |  | BEVINS M | 1 | 1 | P | MIKE B |  |  | 10-065 |  |  |  |  |  | APP |  |  |  | 100 |  |  | 3411A | 11-041 | 13-003F |  |  |  | 09-047 | 10-001A |  |  |  |  |  |  |  |  |  |  |  |  |  |  |  |  |  |  |  |  |  |  |
| 13411087D15 | Vend Fab Septa (S/R Dipoles) Deliver (2) YA Magnet Assemblies (Reverse Entry per CR 11-041) |  | 14d | 2011-06-01 A | 2011-06-20 A | 9-110M FS+162d | 100% |  |  |  |  |  |  | PROCUREMENT>$50K 69 NO ESCALATION | -68,850 |  |  |  | BEVINS M | 1 | 1 | P | MIKE B |  |  | 10-065 |  |  |  |  |  | APP |  |  |  | 100 |  |  | 3411A | 11-041 | 13-003F |  |  |  | 09-047 | 10-001A |  |  |  |  |  |  |  |  |  |  |  |  |  |  |  |  |  |  |  |  |  |  |
| 13411087D7 | Vend Fab Septa (S/R Dipoles) Deliver (2) ZB Coil Sets (Reverse Entry per CR 11-041) |  | 14d | 2011-06-01 A | 2011-06-20 A | 9-110M FS+162d | 100% |  |  |  |  |  |  | PROCUREMENT>$50K 69 NO ESCALATION | -51,000 |  |  |  | BEVINS M | 1 | 1 | P | MIKE B |  |  | 10-065 |  |  |  |  |  | APP |  |  |  | 100 |  |  | 3411A | 11-041 | 13-003F |  |  |  | 09-047 | 10-001A |  |  |  |  |  |  |  |  |  |  |  |  |  |  |  |  |  |  |  |  |  |  |
| 13411087F5 | Stangenes Septa Contract Oversight Labor FY11 |  | 183.27d | 2011-06-01 A | 2012-02-29 A | 9-110M FS+162d | 100% |  |  |  |  |  |  | MECH ENG [453.93 h] | 31,367.34 | 31,367.34 | 0 | 30844.5435 | BEVINS M | 1 | 1 | E | MIKE B |  |  | 10-065 | 12-001 |  |  |  |  | APP |  |  |  |  |  |  | 3411A | 11-041 | 13-003F |  |  |  |  |  | 11.41304347 | 88.58695652 | 100 | 100 |  |  |  |  |  |  |  |  |  |  |  |  |  |  |  |  |  |  |
| 13411087F5a | Stangenes Septa Contract Oversight Labor FY12 |  | 184d | 2011-06-01 A | 2012-02-29 A | 13411087F5 FS-105d | 100% |  |  |  |  |  |  | MECH ENG [517.27 h] | 35,746.34 | 35,746.34 | 0 | 36270.9724 | BEVINS M | 1 | 1 | E | MIKE B |  |  | 10-065 | 12-001 |  |  |  |  | APP |  |  |  |  |  |  | 3411A | 11-041 | 13-003F |  |  |  |  |  | 20.40816326 | 79.59183673 | 100 | 100 |  |  |  |  |  |  |  |  |  |  |  |  |  |  |  |  |  |  |
| 13411087F7 | Completion of Core Machining |  | 217d | 2011-06-01 A | 2012-04-16 A | 9-110M FS+162d | 100% |  |  |  |  |  |  | PROCUREMENT<$50K 60 NO ESCALATION; PROCUREMENT>$50K 69 NO ESCALATION | 100,255 |  | 0 | 100255 | BEVINS M | 1 | 1 | D | MIKE B |  |  | 10-065 |  |  |  |  |  | APP | 0 | 100255 | 10025500 | 100 |  |  | 3411A | 11-041 | 13-003F |  |  |  |  |  |  |  |  |  |  |  |  |  |  |  |  |  |  |  |  |  |  |  |  |  |  |  |
| 13411110M | Delivery Complete for Curved Dipoles (S/R DIPOLES) | milestone | 0d | 2011-08-30 A | 2011-08-30 A | 13411106, 13411105r, 13411108M, 13411105x, 13411106a | 100% |  | 2011-10-03 | 2011-10-03 |  |  |  |  |  |  |  | 0 | BEVINS M | 1 | 1 | M | MIKE B | 08-029 | 10-003 | 10-065 |  | 6 |  |  |  |  |  |  |  |  |  |  |  |  |  |  |  |  |  |  |  |  |  |  |  |  |  |  |  |  |  |  |  |  |  |  |  |  |  |  |  |  |
| 13411135 | Proc & Vend Fab Misc shims & Brackets (S/R Dipoles) Labor FY10 |  | 111d | 2011-09-02 A | 2012-02-19 A | 9-100M FS+60d, 13411909LOE, 9-120M | 100% |  | 2011-09-02 | 2012-02-17 |  |  |  | MECH DES [15.22 h]; MECH ENG [15.22 h]; MECH TECH [15.22 h] | 2,462.96 | 2,462.96 | 0 | 2326.0726 | BEVINS M | 1 | 1 | H | MIKE B | 08-029 |  | 10-065 |  |  |  |  | 12-035F | APP |  |  |  |  |  |  |  |  |  |  |  |  |  |  |  |  |  |  | 08-016 | 09-012 | 09-034 | 11-001 |  |  |  |  |  |  |  |  |  |  |  |  |  |  |
| 13411135a | Proc & Vend Fab Misc shims & Brackets (S/R Dipoles) Labor FY11 |  | 110d | 2011-09-02 A | 2012-02-17 A | 13411135 FS-70d, 9-100M FS+60d, 13411909LOE | 100% |  | 2011-09-02 | 2012-02-16 |  |  |  | MECH DES [20.08 h]; MECH ENG [20.08 h]; MECH TECH [20.08 h] | 3,249.25 | 3,253.2 | 0 | 3166.616 | BEVINS M | 1 | 1 | H | MIKE B | 08-029 |  | 10-065 | 12-001 |  |  |  | 12-035F | APP |  |  |  |  |  |  |  |  |  |  |  |  |  |  |  |  |  |  | 08-016 | 09-012 | 09-034 | 11-001 |  |  |  |  |  |  |  |  |  |  |  |  |  |  |
| 13411135ab | Proc & Vend Fab Misc shims & Brackets (S/R Dipoles) Labor FY12 |  | 111d | 2011-09-02 A | 2012-02-19 A | 13411135a FS-60d | 100% |  | 2011-09-02 | 2012-02-17 |  |  |  | MECH TECH [4.7 h]; MECH DES [4.7 h]; MECH ENG [4.7 h] | 760.58 | 760.58 | 0 | 764.831 | BEVINS M | 1 | 1 | H | MIKE B | 08-029 |  | 10-065 | 12-001 |  |  |  | 12-035F | APP |  |  |  |  |  |  |  |  |  |  |  |  |  |  |  |  |  |  | 08-016 | 09-012 | 09-034 | 11-001 |  |  |  |  |  |  |  |  |  |  |  |  |  |  |
| 13411135b | Proc & Vend Fab Misc shims & Brackets (S/R Dipoles) Procurement |  | 151d | 2011-09-02 A | 2012-04-16 A | 13411909LOE | 100% |  |  |  |  |  |  | PROCUREMENT<$50K 60 | 20,876.92 |  | 0 | 20876.92 | BEVINS M | 1 | 1 | D | MIKE B | 08-029 |  | 10-065 |  |  |  |  | 12-035F | APP | 0 | 20876.92 | 2087692 | 100 |  | 11-057 |  |  |  |  |  |  |  |  |  |  |  |  | 08-016 | 09-012 | 09-034 | 11-001 |  |  |  |  |  |  |  |  |  |  |  |  |  |  |
| 13411195 | Magnet End Shim Form Factor Documentation |  | 151d | 2011-10-03 A | 2012-05-14 A | 9-120M, 9-110M FS+23d | 100% |  |  |  |  |  |  | MECH ENG [280 h]; MECH TECH [760 h] | 53,408 | 53,408 | 0 | 51759.2 | BEVINS M | 1 | 1 | S | MIKE B |  |  | 10-065 |  |  |  |  | 12-035F | APP |  |  |  |  | ST |  |  |  |  |  |  |  |  |  |  |  |  |  |  |  |  |  |  |  |  |  |  |  |  |  |  |  |  |  |  |  |
| 13411912LOE | FY12 Mngmnt & Oversight (S/R Dipoles) |  | 247d | 2011-10-03 A | 2012-09-28 A | 13411911LOE | 100% |  |  |  |  |  |  | SR STAFF [280 h] | 31,640 | 31,640 | 0 | 31640 | BEVINS M | 1 | 1 | E | MIKE B |  |  |  |  |  |  |  |  |  |  |  |  |  |  |  |  |  |  |  |  |  |  |  | 7.69230769 | 92.3076923 | 100 | 100 |  |  |  |  |  |  |  |  |  |  |  |  |  |  |  |  |  |  |
| 13411070M | Deliver Complete for H Steel for S/R Dipoles (S/R DIPOLES) | milestone | 0d | 2011-10-17 A | 2011-10-17 A | 13411066 | 100% |  | 2011-11-14 | 2011-11-14 |  |  |  |  |  |  |  | 0 | BEVINS M | 1 | 1 | M | MIKE B | 08-029 |  |  |  | 6 |  |  |  |  |  |  |  |  |  |  |  |  |  |  |  |  |  |  |  |  |  |  |  |  |  |  |  |  |  |  |  |  |  |  |  |  |  |  |  |  |
| 13411196 | Procurement of CNC Machining Center |  | 110d | 2011-12-01 A | 2012-05-14 A | 9-120M FS+41d | 100% |  |  |  |  |  |  | PROCUREMENT<$50K 60 NO ESCALATION; PROCUREMENT>$50K 69 NO ESCALATION | 155,000 |  | 0 | 155000 | BEVINS M | 1 | 1 | D | MIKE B |  |  |  |  |  |  |  |  |  | 0 | 155000 | 15500000 | 100 |  |  |  |  |  |  |  |  |  |  |  |  |  |  |  |  |  |  | 12-008 |  |  |  |  |  |  |  |  |  |  |  |  |  |
| 13411130M | Delivery Complete for C Dipoles & Coils (S/R DIPOLES) | milestone | 0d | 2011-12-12 A | 2011-12-12 A | 13411105q, 13411126a, 13411105u, 13411126 | 100% |  | 2012-01-12 | 2012-01-12 |  |  |  |  |  |  |  | 0 | BEVINS M | 1 | 1 | M | MIKE B | 08-029 | 10-003 | 10-065 |  | 6 |  |  |  |  |  |  |  |  |  |  |  |  |  |  |  |  |  |  |  |  |  |  |  |  |  |  |  |  |  |  |  |  |  |  |  |  |  |  |  |  |
| 13411139 | Receive and Inspect BCOMM and Additional Steel |  | 45d | 2012-02-13 A | 2012-04-16 A | 13411138a, 13411138 FS-107d | 100% |  |  |  |  |  |  | MECH ENG [80 h]; COMP SCIENT [80 h]; MECH TECH [160 h] | 17,969.6 | 17,969.6 | 0 | 17969.6 | BEVINS M | 1 | 1 | H | MIKE B |  |  | 10-065 |  |  |  | 10-030 | 12-035F | APP |  |  |  |  |  |  |  |  |  |  |  |  |  |  |  |  |  |  |  |  |  |  |  |  |  |  |  |  |  |  |  |  |  |  |  |  |
| 13411145 | Mag Measurement of Septa's (S/R Dipoles) |  | 188d | 2012-05-09 A | 2013-08-30 A | 9-120M, 13411090M FS-120d, 13416048M FS-125d, 13411087A | 100% |  | 2012-05-09 | 2013-02-12 |  |  |  | MECH ENG [280 h]; MECH TECH [496 h] | 42,299.1 | 42,601.41 | 8335.168 | 41675.84 | BEVINS M | 1 | 1 | S | MIKE B | 08-029 |  | 10-065 |  |  |  |  |  |  |  |  |  |  | ST |  |  | 11-041 |  |  | XX | OPC A | 09-047 |  |  |  |  |  |  |  |  |  |  | 08-059 | X |  |  |  |  |  |  |  |  |  |  |  |
| 13411088M | First Septa Dipole Delivery | milestone | 0d | 2012-05-09 A | 2012-05-09 A | 13411087H, 13411087A | 100% |  | 2012-07-03 | 2012-07-03 |  |  |  |  |  |  |  | 0 | BEVINS M | 1 | 1 | M | MIKE B | 08-029 |  | 10-065 |  |  |  |  |  |  |  |  |  |  |  |  |  | 11-041 | 13-003F |  |  |  | 09-047 |  |  |  |  |  |  |  |  |  |  |  |  |  |  |  |  |  |  |  |  |  |  |  |
| 13411088 | Septa Core Shipping Costs |  | 11d | 2012-10-01 A | 2012-10-15 A | 9-130M | 100% |  |  |  |  |  |  | PROCUREMENT>$50K 69 NO ESCALATION | 12,000 |  | 0 | 12000 | BEVINS M | 1 | 1 | H | MIKE B |  |  | 10-065 |  |  |  |  |  | APP | 0 | 12000 | 1200000 | 100 |  |  | 3411A | 11-041 | 13-003 |  |  |  |  |  |  |  |  |  |  |  |  |  |  |  |  |  |  |  |  |  |  |  |  |  |  |  |
| 13411150LOE | Management Oversight of Septa's (S/R Dipoles) 2012 ETC |  | 80d | 2012-10-01 A | 2013-01-31 A | 9-130M | 100% |  |  |  |  |  |  | MECH ENG [690.8 h] | 49,986.29 | 49,986.29 | 0 | 49986.288 | BEVINS M | 1 | 1 | E | MIKE B | 08-029 |  | 10-065 |  |  |  |  |  |  |  |  |  |  |  |  |  | 11-041 | 13-003 |  | XX |  | 09-047 |  | 26.25 | 73.75 | 100 | 100 |  |  |  |  |  | 08-059 |  |  |  |  |  |  |  |  |  |  |  |  |
| 13411950 | Re-Baseline Actuals Adjustment |  | 1d | 2013-08-30 A | 2013-08-30 A |  | 100% |  | 2013-09-03 | 2013-09-03 |  |  |  | PROCUREMENT>$50K 69 NO ESCALATION | 854,402.24 |  |  | 854402.24 |  |  |  |  |  |  |  |  |  |  |  |  |  |  | 0 | 854402.24 | 85440224 | 100 |  |  |  |  |  |  |  |  |  |  |  |  |  |  |  |  |  |  |  |  |  | ADJ |  |  |  |  |  |  |  |  |  |  |
| 13411090M | Delivery Complete for Septa (S/R DIPOLES) | milestone | 0d | 2013-08-30 A | 2013-08-30 A | 13411087D10, 13411087D5, 13411088M, 13411087F, 13411086BLOE, 13411087D15, 13411087D7, 13411087F5a, 13411087C5, 13411087Q, 13411087F7, 13411087D05, 13411088 | 100% |  | 2013-09-30 | 2013-09-30 |  |  |  |  |  |  |  | 0 | BEVINS M | 1 | 1 | M | MIKE B | 08-029 |  | 10-065 |  | 6 |  |  |  |  |  |  |  |  |  |  |  | 11-041 | 13-003 |  | XX | OPC A | 09-047 |  |  |  |  |  |  |  |  |  |  | 08-059 |  |  |  |  |  |  |  |  |  |  |  |  |
| 23411087N | Vend Fab Septa (S/R Dipoles) Peg Point #5 Delivery and Acceptance of ZA Spare Coil Set |  | 31d | 2013-09-03 A | 2013-11-15 | 9-130M FS+228d | 50% | 11d | 2013-10-01 | 2013-11-12 | 121d | 20d | 8/5 M-F w/JLAB Holidays ReBaseline | PROCUREMENT>$50K 69 NO ESCALATION | 21,500 |  |  | 0 | BEVINS M | 1 | 1 | D | MIKE B |  |  | 10-065 |  |  |  |  |  | APP | 10750 | 10750 | 1075000 | 100 |  |  | 3411A | 11-041 | 13-003F |  |  |  |  |  |  |  |  |  |  |  |  |  |  |  |  |  | Open Obligation | 23411087N | 10750 | OB | 13-015 | PR | OB |  |  |  |
| 23411087Q | Vend Fab Septa (S/R Dipoles) Peg Point #7 Delivery and Acceptance of Quantity 2 ZB Coil Sets |  | 31d | 2013-09-03 A | 2013-11-15 | 23411087N FS-31d | 50% | 11d | 2013-10-01 | 2013-11-12 | 101d | 0d | 8/5 M-F w/JLAB Holidays ReBaseline | PROCUREMENT>$50K 69 NO ESCALATION | 34,500 |  |  | 0 | BEVINS M | 1 | 1 | D | MIKE B |  |  | 10-065 |  |  |  |  |  | APP | 17250 | 17250 | 1725000 | 100 |  |  | 3411A | 11-041 | 13-003F |  |  |  |  |  |  |  |  |  |  |  |  |  |  |  |  |  | Open Obligation | 23411087Q | 17250 | OB | 13-015 | PR | OB |  |  |  |
| 23411145 | Mag Measurement of Septa's (S/R Dipoles) FY13 |  | 20d | 2013-09-03 A | 2013-09-23 A | 23411090M FS-50d | 100% |  | 2013-10-01 | 2013-10-28 |  |  | 8/5 M-F w/JLAB Holidays ReBaseline | MECH ENG [12.69 h]; MECH TECH [52.11 h] | 3,413.41 | 3,308.01 |  | 0 | BEVINS M | 1 | 1 | H | MIKE B | 08-029 |  | 10-065 |  |  |  |  |  |  |  |  |  |  |  |  |  | 11-041 |  |  |  |  | 09-047 |  |  |  |  |  |  |  |  |  |  | 08-059 |  |  |  | 23411145 | 3308.013 |  | 13-015 | PR |  | PE | LR13 |  |
| 23411145a | Mag Measurement of Septa's (S/R Dipoles) FY14 |  | 11d | 2013-09-03 A | 2013-09-23 A | 23411145 | 100% |  | 2013-10-01 | 2013-10-15 |  |  | 8/5 M-F w/JLAB Holidays ReBaseline | MECH ENG [15.51 h]; MECH TECH [63.69 h] | 4,171.94 | 4,043.12 |  | 0 | BEVINS M | 1 | 1 | H | MIKE B | 08-029 |  | 10-065 |  |  |  |  |  |  |  |  |  |  |  |  |  | 11-041 |  |  |  |  | 09-047 |  |  |  |  |  |  |  |  |  |  | 08-059 |  |  |  | 23411145 | 4171.9425 |  | 13-015 | PR |  | PE | LR13 | 14-001 |
| 23411090M | Delivery Complete for Septa (S/R DIPOLES) | milestone | 0d | 2013-11-15 | 2013-11-15 | 23411087Q |  |  |  |  | 101d | 39d | 8/5 M-F w/JLAB Holidays ReBaseline |  |  |  |  | 0 | BEVINS M | 1 | 1 | M | MIKE B | 08-029 |  | 10-065 |  | 6 |  |  |  |  |  |  |  |  |  |  |  | 11-041 | 13-003 |  |  |  | 09-047 |  |  |  |  |  |  |  |  |  |  | 08-059 |  |  |  | 23411090M |  |  | 13-015 | PR |  |  |  |  |

Notes:
- 13411136M: Explanation: IPL from 6 GeV BIA 534213060 and / 534213120
- 13411138: Steps: Materials (done); Receive 1st Article XT (done); Receive remaining XT (2) (done); Receive XS (2) (done); Receive XN core (2) (done); Receive 1m Spare Steel (3) (done); Receive 3m Spare Steel (1) (done)
- 13411138a: Steps: Materials (done); Receive 1st Article XT (done); Receive remaining XT (2) (done); Receive XS (2) (done); Receive XN core (2) (done); Receive 1m Spare Steel (3) (done); Receive 3m Spare Steel (1) (done)
- 13411195: Steps: Survey past data (done); Parameterize Shim System (done); Finalize System Designs and Documentation (done)
- 13411145: Steps: Measure Septa Part 1 (done); Measure Septa Part 2 (done); Measure Septa Part 3 (done); Measure Septa Part 4 (done); Measure Septa Part 5 (done)

| ID | WBS | Activity | Type | Duration | Start | Finish | Predecessors | Complete | Planned start | Planned finish | Resources | Cost | Actual cost | Calculated Remaining Total Cost | MONTHLY EV COST | RESP - Responsibility | STRT%COMP for CM EVM | FNSH%COMP for CM EVM | CR 08-016 | EVMS Reporting Codes | CAM RESPONSIBLE | CR 09-012 | CR 10-030 | Activities with Steps | CR 10-065 | CR 11-057 | CR 12-035 | CR 12-039 | Remaining Material Cost Based on % Compl | Claimed Material Cost Based on % Complet | Initial Claimed Material Calc | Claimed Material Divider | LOE % Pre Calc | LOE % | LOE Divider | LOE Multiplier | Milestone Level | Phil Dev | OPC Allison | CR 12-053 | ReBaseline Actuals Adjustment |
| --- | --- | --- | --- | --- | --- | --- | --- | --- | --- | --- | --- | --- | --- | --- | --- | --- | --- | --- | --- | --- | --- | --- | --- | --- | --- | --- | --- | --- | --- | --- | --- | --- | --- | --- | --- | --- | --- | --- | --- | --- | --- |
|  | 2 | **1.3.4.1.2 QUADRUPOLES** |  |  |  |  |  |  |  |  |  |  |  |  |  |  |  |  |  |  |  |  |  |  |  |  |  |  |  |  |  |  |  |  |  |  |  |  |  |  |  |
|  | 3 | **1.3.4.1.3 CORRECTORS** |  |  |  |  |  |  |  |  |  |  |  |  |  |  |  |  |  |  |  |  |  |  |  |  |  |  |  |  |  |  |  |  |  |  |  |  |  |  |  |
|  | 4 | **1.3.4.1.4 STANDS** |  |  | 2010-03-01 | 2013-08-30 |  |  |  |  |  |  |  |  |  |  |  |  |  |  |  |  |  |  |  |  |  |  |  |  |  |  |  |  |  |  |  |  |  |  |  |
| 13414055 |  | Vend Fab S/R Cartridges & Brackets (S/R Stands) (Original) |  | 1d | 2010-03-01 A | 2010-03-01 A | 9-100M FS+60d | 100% |  |  | MECH DES [21.3 h]; MECH TECH [6.82 h]; MECH ENG [9.55 h] | 1,877.15 | 1,877.15 | 0 | 1877.1463 | BEVINS M | 1 | 1 | 08-016 | H | MIKE B | 09-012 | 10-030 |  |  |  |  |  |  |  |  |  |  |  |  |  |  |  |  |  |  |
| 13414015 |  | Prcrmnt Prep of New S/R Stands (S/R Stands) Initial |  | 92d | 2010-03-22 A | 2010-07-29 A | 9-100M FS+97d, 121414016, 121416010, 121414020a, 121414015a | 100% |  |  | MECH DES [3200 h]; MECH ENG [1600 h] | 250,128 | 250,128 | 0 | 250128 | BEVINS M | 1 | 1 |  | S | MIKE B |  | 10-030 | ST | 10-065 | 11-057 | 12-035F | 12-039F |  |  |  |  |  |  |  |  |  |  |  |  |  |
| 13414017 |  | Prcrmnt Prep of New S/R Stands (S/R Stands) Final |  | 165d | 2010-08-23 A | 2011-04-25 A | 121414016, 9-110M FS-20d, 13414015, 121416010, 121414020a, 121414015a | 100% |  |  | MECH ENG [800 h]; MECH DES [1600 h] | 128,371.93 | 128,371.93 | 0 | 129048 | BEVINS M | 1 | 1 |  | S | MIKE B |  | 10-030 | ST | 10-065 | 11-057 | 12-035F | 12-039F |  |  |  |  |  |  |  |  |  |  |  |  |  |
| 13414060 |  | Procurement Prep of S/R Brackets (S/R Stands) |  | 301d | 2011-02-01 A | 2012-04-16 A | 9-110M | 100% |  |  | MECH DES [160 h]; MECH ENG [240 h] | 24,107.22 | 24,107.22 | 0 | 23776.8 | BEVINS M | 1 | 1 |  | H | MIKE B |  | 10-030 |  | 10-065 | 11-057 | 12-035F |  |  |  |  |  |  |  |  |  |  |  |  |  |  |
| 13414100 |  | Vend Fab New Girders for S/R (S/R Stands) |  | 90d | 2011-12-01 A | 2012-04-16 A | 9-120M, 9-110M FS+120d | 100% |  |  | PROCUREMENT>$50K 69 | 26,829.4 |  | 0 | 26829.4 | BEVINS M | 1 | 1 |  | D | MIKE B |  | 10-030 |  | 10-065 |  | 12-035F |  | 0 | 26829.4 | 2682940 | 100 |  |  |  |  |  |  |  |  |  |
| 13414022LOE |  | Vend Fab New S/R Stands (S/R Stands) Oversight |  | 81d | 2011-12-14 A | 2012-04-16 A | 13414020M FS-40d | 100% |  |  | MECH DES [80 h]; MECH ENG [120 h] | 12,268 | 12,268 | 0 | 12268 | BEVINS M | 1 | 1 |  | E | MIKE B |  | 10-030 |  | 10-065 | 11-057 | 12-035F |  |  |  |  |  | 9.90099009 | 90.0990099 | 100 | 100 |  |  |  |  |  |
| 13414070LOE |  | Vend Fab S/R Brackets (S/R Stands) Oversight |  | 65d | 2011-12-21 A | 2012-03-30 A | 13414060 FS-20d, 13414065M FS-40d | 100% |  |  | MECH ENG [40 h]; MECH DES [40 h] | 4,731.6 | 4,731.6 | 0 | 4731.6 | BEVINS M | 1 | 1 |  | E | MIKE B |  | 10-030 |  | 10-065 | 11-057 | 12-035F |  |  |  |  |  | 33.84615384 | 66.15384615 | 100 | 100 |  |  |  |  |  |
| 13414028 |  | Reverse Entry Per CR 12-035 |  | 6d | 2012-04-02 A | 2012-04-09 A | 9-120M FS+120d | 100% |  |  | MECH TECH [-114.35 h]; MECH ENG [-25.06 h]; MECH DES [-27.53 h] | -8,165.04 | -8,165.04 |  |  | BEVINS M | 1 | 1 |  | Z | MIKE B |  | 10-030 |  | 10-065 | 11-057 | 12-035 |  |  |  |  |  |  |  |  |  |  |  |  |  |  |
| 13414090 |  | Receive and Inspect S/R Brackets (S/R Stands) Frozen Per CR 12-035 |  | 6d | 2012-04-02 A | 2012-04-09 A | 13414075 FS-30d | 100% |  |  | MECH TECH [72 h]; MECH ENG [18 h]; MECH DES [24 h] | 5,617.92 | 5,617.92 | 0 | 5617.92 | BEVINS M | 1 | 1 |  | U | MIKE B |  | 10-030 |  | 10-065 | 11-057 | 12-035 |  |  |  |  |  |  |  |  |  |  |  |  |  |  |
| 13414027 |  | Receive and Inspect to S/R Stands Frozen Per CR 12-035 |  | 6d | 2012-04-09 A | 2012-04-16 A |  | 100% |  |  | MECH TECH [42.35 h]; MECH ENG [7.06 h]; MECH DES [3.53 h] | 2,547.12 | 2,547.12 | 0 | 2547.1213 | BEVINS M | 1 | 1 |  | U | MIKE B |  | 10-030 |  | 10-065 | 11-057 | 12-035 |  |  |  |  |  |  |  |  |  |  |  |  |  |  |
| 13414020M |  | Award Contract for New S/R Stands (S/R STANDS) | milestone | 0d | 2012-04-16 A | 2012-04-16 A | 9-120M FS+141d, 13414017 | 100% | 2012-05-01 | 2012-05-01 |  |  |  |  | 0 | BEVINS M | 1 | 1 |  | M | MIKE B |  | 10-030 |  | 10-065 | 11-057 | 12-035F | 12-039 |  |  |  |  |  |  |  |  | 6 |  |  |  |  |
| 13414025A |  | Vend Fab Stands Peg Point #1 Receipt of Material |  | 39d | 2012-04-16 A | 2012-06-11 A | 13414020M | 100% |  |  | PROCUREMENT<$50K 60 NO ESCALATION; PROCUREMENT>$50K 69 NO ESCALATION | 269,669.11 |  | 0 | 269669.11 | BEVINS M | 1 | 1 |  | D | MIKE B |  | 10-030 |  | 10-065 | 11-057 | 12-035 | 12-039 | 0 | 269669.11 | 26966911 | 100 |  |  |  |  |  |  |  |  |  |
| 13414025B |  | Vend Fab Stands Peg Point #2 Receipt and Acceptance of Finished Stands 002-015 (Qty 14) |  | 98d | 2012-04-16 A | 2012-08-31 A | 13414025A FS-64d | 100% |  |  | PROCUREMENT>$50K 69 NO ESCALATION | 123,397.68 |  | 0 | 123397.68 | BEVINS M | 1 | 1 |  | D | MIKE B |  |  |  |  |  |  | 12-039 | 0 | 123397.68 | 12339768 | 100 |  |  |  |  |  | MP |  |  |  |
| 13414025C |  | Vend Fab Stands Peg Point #3 Receipt and Acceptance of Finished Stands 016-029 (Qty 14) |  | 108d | 2012-04-16 A | 2012-09-17 A | 13414025B FS-87d | 100% |  |  | PROCUREMENT>$50K 69 NO ESCALATION | 128,457.55 |  | 0 | 128457.55 | BEVINS M | 1 | 1 |  | D | MIKE B |  |  |  |  |  |  | 12-039 | 0 | 128457.55 | 12845755 | 100 |  |  |  |  |  | MP |  |  |  |
| 13414025D |  | Vend Fab Stands Peg Point #4 Receipt and Acceptance of Finished Stands 030-040 (Qty 11) |  | 133d | 2012-04-16 A | 2012-10-22 A | 13414025C FS-106d | 100% |  |  | PROCUREMENT>$50K 69 NO ESCALATION | 100,931.05 |  | 0 | 100931.05 | BEVINS M | 1 | 1 |  | D | MIKE B |  |  |  |  |  |  | 12-039 | 0 | 100931.05 | 10093105 | 100 |  |  |  |  |  | MP | OPC A |  |  |
| 13414025F |  | Vend Fab Stands Peg Point #5 Receipt and Acceptance of Finished Stands 041-051 (Qty 11) |  | 171d | 2012-04-16 A | 2012-11-12 A | 13414025D FS-129d | 100% | 2012-04-16 | 2012-12-17 | PROCUREMENT>$50K 69 NO ESCALATION | 108,182.61 |  | 0 | 108182.61 | BEVINS M | 1 | 1 |  | D | MIKE B |  |  |  |  |  |  | 12-039 | 0 | 108182.61 | 10818261 | 100 |  |  |  |  |  | MP | OPC A |  |  |
| 13414025G |  | Vend Fab Stands Peg Point #6 Receipt and Acceptance of Finished Stands 052-071 (Qty 20) |  | 176d | 2012-04-16 A | 2012-12-17 A | 13414025F FS-149d | 100% | 2012-04-16 | 2012-12-31 | PROCUREMENT>$50K 69 NO ESCALATION | 168,259 |  | 0 | 168259 | BEVINS M | 1 | 1 |  | D | MIKE B |  |  |  |  |  |  | 12-039 | 0 | 168259 | 16825900 | 100 |  |  |  |  |  | MP | OPC A |  |  |
| 13414065M |  | Award Contract for Brackets (S/R Stands) | milestone | 0d | 2012-06-15 A | 2012-06-15 A | 9-120M FS+90d, 13414060 | 100% | 2012-07-02 | 2012-07-02 |  |  |  |  | 0 | BEVINS M | 1 | 1 |  | M | MIKE B |  | 10-030 |  | 10-065 | 11-057 | 12-035F |  |  |  |  |  |  |  |  |  | 6 |  |  |  |  |
| 13414075 |  | Vend Fab S/R Brackets (S/R Stands) |  | 86d | 2012-06-15 A | 2012-10-15 A | 13414065M | 100% |  |  | PROCUREMENT>$50K 69; PROCUREMENT<$50K 60 | 86,250.23 |  | 0 | 86250.23 | BEVINS M | 1 | 1 |  | D | MIKE B |  | 10-030 |  | 10-065 | 11-057 | 12-035 |  | 0 | 86250.23 | 8625023 | 100 |  |  |  |  |  | MP |  |  |  |
| 13414029 |  | Receive and Inspect to S/R Stands Revised Per CR 12-035 FY12 |  | 82d | 2012-08-27 A | 2012-12-17 A | 13414025G FS-90d, 13414025A | 100% | 2012-08-27 | 2012-12-21 | MECH TECH [167.19 h]; MECH ENG [27.87 h]; MECH DES [13.93 h] | 10,282.43 | 10,295.53 | 0 | 10055.1761 | BEVINS M | 1 | 1 |  | U | MIKE B |  | 10-030 |  | 10-065 | 11-057 | 12-035 |  |  |  |  |  |  |  |  |  |  |  | OPC A | 12-053 |  |
| 13414029a |  | Receive and Inspect to S/R Stands Revised Per CR 12-035 FY13 |  | 82d | 2012-08-27 A | 2012-12-17 A | 13414029 FS-75d | 100% | 2012-08-27 | 2012-12-21 | MECH TECH [312.81 h]; MECH ENG [52.13 h]; MECH DES [26.07 h] | 19,237.6 | 19,228.58 | 0 | 19413.5331 | BEVINS M | 1 | 1 |  | U | MIKE B |  | 10-030 |  | 10-065 | 11-057 | 12-035 |  |  |  |  |  |  |  |  |  |  |  |  | 12-053 |  |
| 13414092 |  | Receive and Inspect S/R Brackets (S/R Stands) Revised Per CR 12-035 |  | 35d | 2012-08-27 A | 2012-10-15 A | 13414075 FS-54d | 100% |  |  | MECH TECH [240 h]; MECH ENG [60 h]; MECH DES [80 h] | 18,914.47 | 18,914.47 | 0 | 18726.4 | BEVINS M | 1 | 1 |  | U | MIKE B |  | 10-030 |  | 10-065 | 11-057 | 12-035 |  |  |  |  |  |  |  |  |  |  |  |  |  |  |
| 13414095M |  | Delivery Complete for S/R Cartridges & Brackets (S/R Stands) | milestone | 0d | 2012-10-15 A | 2012-10-15 A | 13414070LOE, 13414092, 13414090 | 100% | 2012-11-15 | 2012-11-15 |  |  |  |  | 0 | BEVINS M | 1 | 1 |  | M | MIKE B |  | 10-030 |  | 10-065 | 11-057 | 12-035 |  |  |  |  |  |  |  |  |  | 6 |  |  |  |  |
| 13414030M |  | Delivery Complete for New S/R Stands (S/R STANDS) | milestone | 0d | 2012-12-17 A | 2012-12-17 A | 13414022LOE, 13414027, 13414029a, 13414025A FS-10d | 100% | 2013-01-23 | 2013-01-23 |  |  |  |  | 0 | BEVINS M | 1 | 1 |  | M | MIKE B |  | 10-030 |  | 10-065 | 11-057 | 12-035 |  |  |  |  |  |  |  |  |  | 6 |  | OPC A |  |  |
| 13414105 |  | Re-Baseline Actuals Adjustment |  | 1d | 2013-08-30 A | 2013-08-30 A |  | 100% | 2013-09-03 | 2013-09-03 | PROCUREMENT>$50K 69 NO ESCALATION | 462,300.33 |  |  | 462300.33 |  |  |  |  |  |  |  |  |  |  |  |  |  | 0 | 462300.33 | 46230033 | 100 |  |  |  |  |  |  |  |  | ADJ |

Notes:
- 13414015: Steps: East Spreader (done); East Recombiner (done); West Spreader (done); West Recombiner (done); Transport Recombiner (done)
- 13414017: Steps: East Spreader (done); East Recombiner (done); West Spreader (done); West Recombiner (done); Transport Recombiner (done)

| ID | WBS | Activity | Type | Duration | Start | Finish | Predecessors | Complete | Remaining | Planned start | Planned finish | Total float | Free float | Calendar | Resources | Cost | Actual cost | Calculated Remaining Total Cost | MONTHLY EV COST | RESP - Responsibility | STRT%COMP for CM EVM | FNSH%COMP for CM EVM | EVMS Reporting Codes | CAM RESPONSIBLE | CR 09-034 | CR 10-030 | CR 10-065 | CR 11-057 | Profile change | CR 08-016 | CR 09-012 | CR 11-041 | LOE Divider | LOE Multiplier | CR 07-024 | Duplications | MARCH!!! | Activities with Steps | Remaining Material Cost Based on % Compl | Claimed Material Cost Based on % Complet | Initial Claimed Material Calc | Claimed Material Divider | CR 12-035 | Milestone Level | CR 11-001 | In Progress Procurements | ReBaseline Actuals Adjustment | LOE % Pre Calc | LOE % | Installation | CR 13-003 | Specification | OPC Allison | CR 12-053 | Original Activity ID Rebaseline | PRIOR MONTH EV COST | BOE Labor | CR 13-015 | Post Rebaseline | CR 14-001 | BOE Expenses | Obligated Prior to Rebaseline |
| --- | --- | --- | --- | --- | --- | --- | --- | --- | --- | --- | --- | --- | --- | --- | --- | --- | --- | --- | --- | --- | --- | --- | --- | --- | --- | --- | --- | --- | --- | --- | --- | --- | --- | --- | --- | --- | --- | --- | --- | --- | --- | --- | --- | --- | --- | --- | --- | --- | --- | --- | --- | --- | --- | --- | --- | --- | --- | --- | --- | --- | --- | --- |
|  | 5 | **1.3.4.1.5 GIRDERS** |  |  |  |  |  |  |  |  |  |  |  |  |  |  |  |  |  |  |  |  |  |  |  |  |  |  |  |  |  |  |  |  |  |  |  |  |  |  |  |  |  |  |  |  |  |  |  |  |  |  |  |  |  |  |  |  |  |  |  |  |
|  | 6 | **1.3.4.1.6 VACUUM** |  |  | 2009-12-21 | 2013-08-30 |  |  |  |  |  |  |  |  |  |  |  |  |  |  |  |  |  |  |  |  |  |  |  |  |  |  |  |  |  |  |  |  |  |  |  |  |  |  |  |  |  |  |  |  |  |  |  |  |  |  |  |  |  |  |  |  |
| 13416020 |  | Prcrmnt Prep of S/R Dipole Chambers (S/R Vac) Initial |  | 63d | 2009-12-21 A | 2010-03-29 A | 121416005a, 9-100M FS+60d, 121416000a, 121416010 | 100% |  | 2009-12-28 | 2010-03-29 |  |  |  | MECH DES [32 h]; MECH ENG [160 h] | 11,983.68 | 11,983.68 | 0 | 11983.68 | BEVINS M | 1 | 1 | H | MIKE B | 09-034 | 10-030 | 10-065 | 11-057 |  |  |  |  |  |  |  |  |  |  |  |  |  |  |  |  |  |  |  |  |  |  |  |  |  |  |  |  |  |  |  |  |  |  |
| 13416040 |  | Procurement Prep of S/R Septa Chambers (S/R Vac) |  | 25d | 2010-03-22 A | 2010-04-23 A | 9-100M FS+97d | 100% |  |  |  |  |  |  | MECH DES [480 h]; MECH ENG [240 h] | 37,519.2 | 37,519.2 | 0 | 37519.2 | BEVINS M | 1 | 1 | H | MIKE B |  | 10-030 | 10-065 |  | C | 08-016 | 09-012 | 11-041 |  |  |  |  |  |  |  |  |  |  |  |  |  |  |  |  |  |  |  |  |  |  |  |  |  |  |  |  |  |  |
| 13416042LOE |  | Vend Fab S/R Septa Chambers (S/R Vac) Oversight |  | 106d | 2010-04-23 A | 2010-09-22 A | 13416040 FS-7d | 100% |  |  |  |  |  |  | MECH ENG [40 h]; MECH DES [40 h] | 4,443.6 | 4,443.6 | 0 | 4443.6 | BEVINS M | 1 | 1 | E | MIKE B |  | 10-030 | 10-065 |  |  |  |  | 11-041 | 100 | 100 |  |  |  |  |  |  |  |  |  |  |  |  |  |  |  |  |  |  |  |  |  |  |  |  |  |  |  |  |
| 13416045 |  | Vend Fab S/R Septa Chambers- ZAs (S/R Vac) ORG |  | 414d | 2010-04-23 A | 2011-12-19 A | 13416040 FS-7d | 100% |  |  |  |  |  |  | MSHOP | 36,635.51 |  | 0 | 36635.51 | BEVINS M | 1 | 1 | D | MIKE B |  | 10-030 | 10-065 |  |  |  |  | 11-041 |  |  | 07-024 | DUP |  |  |  |  |  |  |  |  |  |  |  |  |  |  |  |  |  |  |  |  |  |  |  |  |  |  |
| 13416046 |  | Vend Fab S/R Septa Chambers- YRs (S/R Vac) ORG |  | 663d | 2010-04-23 A | 2013-01-18 A | 13416045 FS-105d | 100% |  | 2010-04-23 | 2012-12-19 |  |  |  | MSHOP | 4,615.38 |  | 0 | 4615.38 | BEVINS M | 1 | 1 | D | MIKE B |  | 10-030 | 10-065 |  |  |  |  | 11-041 |  |  |  | DUP | XX |  |  |  |  |  |  |  |  |  |  |  |  |  |  |  |  |  |  |  |  |  |  |  |  |  |
| 13416047 |  | Vend Fab S/R Septa Chambers- YB (S/R Vac) |  | 618d | 2010-04-23 A | 2012-10-15 A | 13416046 FS-100d | 100% |  |  |  |  |  |  | MSHOP | 5,159.5 |  | 0 | 5159.5 | BEVINS M | 1 | 1 | D | MIKE B |  | 10-030 | 10-065 |  |  |  |  | 11-041 |  |  |  | DUP |  |  |  |  |  |  |  |  |  |  |  |  |  |  |  |  |  |  |  |  |  |  |  |  |  |  |
| 13416025 |  | Prcrmnt Prep of S/R Dipole Chambers (S/R Vac) Final |  | 106d | 2010-08-23 A | 2011-01-31 A | 9-110M FS-20d | 100% |  |  |  |  |  |  | MECH DES [800 h]; MECH ENG [320 h] | 58,606.19 | 58,606.19 | 0 | 59088 | BEVINS M | 1 | 1 | S | MIKE B |  | 10-030 | 10-065 | 11-057 |  |  |  |  |  |  |  |  |  | ST |  |  |  |  |  |  |  |  |  |  |  |  |  |  |  |  |  |  |  |  |  |  |  |  |
| 13416049A |  | Vend Fab New Bellows (S/R Vac) |  | 51d | 2010-12-01 A | 2011-02-21 A | 9-110M | 100% |  | 2010-12-01 | 2011-02-18 |  |  |  | PROCUREMENT<$50K 60 | 22,677.03 |  | 0 | 22677.03 | BEVINS M | 1 | 1 | D | MIKE B |  | 10-030 | 10-065 |  |  |  |  |  |  |  |  | DUP |  |  | 0 | 22677.03 | 2267703 | 100 | 12-035F |  |  |  |  |  |  |  |  |  |  |  |  |  |  |  |  |  |  |  |
| 13416046a |  | Vend Fab S/R Septa Chambers- YRs (S/R Vac) REDESIGN |  | 262d | 2011-12-01 A | 2013-01-18 A | 13416046 FS-110d | 100% |  | 2011-12-01 | 2012-12-19 |  |  |  | MSHOP | 13,811.59 |  | 0 | 13811.59 | BEVINS M | 1 | 1 | D | MIKE B |  |  | 10-065 |  |  |  |  | 11-041 |  |  |  | DUP | XX |  |  |  |  |  |  |  |  |  |  |  |  |  |  |  |  |  |  |  |  |  |  |  |  |  |
| 13416025M |  | Award Contract for S/R Dipole Chambers (S/R VACUUM) | milestone | 0d | 2011-12-12 A | 2011-12-12 A | 13416025, 13416020, 9-120M FS+50d | 100% |  | 2012-01-03 | 2012-01-03 |  |  |  |  |  |  |  | 0 | BEVINS M | 1 | 1 | M | MIKE B | 09-034 | 10-030 | 10-065 | 11-057 |  |  |  |  |  |  |  |  |  |  |  |  |  |  |  | 6 |  |  |  |  |  |  |  |  |  |  |  |  |  |  |  |  |  |  |
| 13416030 |  | Vend Fab S/R Dipole Chambers (S/R Vac) |  | 83d | 2011-12-12 A | 2012-04-16 A | 13416025M | 100% |  |  |  |  |  |  | PROCUREMENT>$50K 69; PROCUREMENT<$50K 60 | 74,537.23 |  | 0 | 74537.23 | BEVINS M | 1 | 1 | D | MIKE B | 09-034 | 10-030 | 10-065 | 11-057 |  |  |  |  |  |  |  |  |  |  | 0 | 74537.23 | 7453723 | 100 |  |  |  |  |  |  |  |  |  |  |  |  |  |  |  |  |  |  |  |  |
| 13416045a |  | Vend Fab S/R Septa Chambers- ZAs (S/R Vac) REDESIGN FY10 |  | 250d | 2011-12-19 A | 2013-06-17 A | 13416045 | 100% |  | 2011-12-19 | 2012-12-19 |  |  |  | MSHOP | 11,675.05 |  | 0 | 11675.05 | BEVINS M | 1 | 1 | D | MIKE B |  |  | 10-065 |  |  |  |  | 11-041 |  |  |  | DUP | XX |  |  |  |  |  |  |  | 11-001 |  |  |  |  |  |  |  |  |  |  |  |  |  |  |  |  |  |
| 13416045ab |  | Vend Fab S/R Septa Chambers- ZAs (S/R Vac) REDESIGN FY11 |  | 250d | 2011-12-19 A | 2013-06-17 A | 13416045a FS-80d, 13416045 | 100% |  | 2011-12-19 | 2012-12-19 |  |  |  | MSHOP | 32,700.33 |  | 0 | 32700.33 | BEVINS M | 1 | 1 | D | MIKE B |  |  | 10-065 |  |  |  |  | 11-041 |  |  |  | DUP | XX |  |  |  |  |  |  |  | 11-001 |  |  |  |  |  |  |  |  |  |  |  |  |  |  |  |  |  |
| 13416032 |  | Receive and Inspect S/R Dipole Chambers (S/R Vac) |  | 26d | 2012-03-12 A | 2012-04-16 A | 13416030 FS-30d | 100% |  |  |  |  |  |  | MECH TECH [80 h]; MECH ENG [60 h] | 7,762.4 | 7,762.4 | 0 | 7762.4 | BEVINS M | 1 | 1 | U | MIKE B |  | 10-030 | 10-065 | 11-057 |  |  |  |  |  |  |  |  |  |  |  |  |  |  |  |  |  |  |  |  |  |  |  |  |  |  |  |  |  |  |  |  |  |  |
| 13416049B |  | Proc Vac Materials Flanges/Gaskets/Hardware (S/R Vac) |  | 59d | 2012-03-19 A | 2012-06-11 A | 9-110M, 9-120M FS+85d | 100% |  |  |  |  |  |  | PROCUREMENT<$50K 60 | 26,078.18 |  | 0 | 26078.18 | BEVINS M | 1 | 1 | D | MIKE B |  | 10-030 | 10-065 |  |  |  |  |  |  |  |  | DUP |  |  | 0 | 26078.18 | 2607818 | 100 | 12-035F |  |  |  |  |  |  |  |  |  |  |  |  |  |  |  |  |  |  |  |
| 13416035M |  | Delivery Complete for S/R Dipole Chambers (S/R VACUUM) | milestone | 0d | 2012-04-16 A | 2012-04-16 A | 13416030, 13416032 | 100% |  | 2012-05-30 | 2012-05-30 |  |  |  |  |  |  |  | 0 | BEVINS M | 1 | 1 | M | MIKE B | 09-034 | 10-030 | 10-065 | 11-057 |  |  |  |  |  |  |  |  |  |  |  |  |  |  |  | 6 |  |  |  |  |  |  |  |  |  |  |  |  |  |  |  |  |  |  |
| 13416049 |  | Vend Fab New Drift Tubes (S/R Vac) |  | 170d | 2012-05-01 A | 2013-05-13 A | 9-120M FS+144d | 100% |  | 2012-05-01 | 2013-01-08 |  |  |  | PROCUREMENT<$50K 60 | 70,125.12 |  | 0 | 70125.12 | BEVINS M | 1 | 1 | D | MIKE B |  | 10-030 |  | 11-057 |  |  |  |  |  |  |  |  | XX |  | 0 | 70125.12 | 7012512 | 100 | 12-035 |  |  | Split |  |  |  |  |  |  |  |  |  |  |  |  |  |  |  |  |
| 13416048M |  | Fabrication Complete S/R Septa Chambers (S/R Vac) | milestone | 0d | 2013-06-17 A | 2013-06-17 A | 13416045ab, 13416045a, 13416046a, 13416045, 13416042LOE, 13416046, 13416047 | 100% |  | 2013-07-18 | 2013-07-18 |  |  |  |  |  |  |  | 0 | BEVINS M | 1 | 1 | M | MIKE B |  | 10-030 | 10-065 |  |  |  |  | 11-041 |  |  |  |  | XX |  |  |  |  |  |  | 6 |  |  |  |  |  |  |  |  |  |  |  |  |  |  |  |  |  |  |
| 13416050 |  | Re-Baseline Actuals Adjustment |  | 1d | 2013-08-30 A | 2013-08-30 A |  | 100% |  | 2013-09-03 | 2013-09-03 |  |  |  | PROCUREMENT>$50K 69 NO ESCALATION | 238,648.55 |  |  | 238648.55 |  |  |  |  |  |  |  |  |  |  |  |  |  |  |  |  |  |  |  | 0 | 238648.55 | 23864855 | 100 |  |  |  |  | ADJ |  |  |  |  |  |  |  |  |  |  |  |  |  |  |  |
|  | 7 | **1.3.4.1.7 INSTALLATION** |  |  | 2011-11-14 | 2013-12-12 |  |  |  |  |  |  |  |  |  |  |  |  |  |  |  |  |  |  |  |  |  |  |  |  |  |  |  |  |  |  |  |  |  |  |  |  |  |  |  |  |  |  |  |  |  |  |  |  |  |  |  |  |  |  |  |  |
| 13417015 |  | Accelerator Down Planning Activity |  | 115d | 2011-11-14 A | 2012-05-04 A | 4A-04M | 100% |  |  |  |  |  |  | MECH ENG [2000 h]; MECH TECH [1000 h] | 184,680 | 184,680 | 0 | 184680 | BEVINS M | 1 | 1 | E | MIKE B |  |  | 10-065 |  |  |  |  |  | 100 | 100 |  |  |  |  |  |  |  |  |  |  |  |  |  | 3.47826086 | 96.52173913 | Install |  |  |  |  |  |  |  |  |  |  |  |  |
| 13417155 |  | LCW Hoses FY12 |  | 49d | 2012-04-02 A | 2012-06-11 A | 9-120M FS+120d | 100% |  |  |  |  |  |  | PROCUREMENT>$50K 69; PROCUREMENT<$50K 60 | 85,000 |  | 0 | 85000 | BEVINS M | 1 | 1 | D | MIKE B |  |  |  |  |  |  |  |  |  |  |  |  |  |  | 0 | 85000 | 8500000 | 100 | 12-035 |  |  |  |  |  |  |  | 13-003F |  |  |  |  |  |  |  |  |  |  |  |
| 13417165 |  | Material handling/tooling/transporation FY12 |  | 127d | 2012-04-02 A | 2012-09-28 A | 9-120M FS+120d | 100% |  |  |  |  |  |  | PROCUREMENT<$50K 60 | 50,000 |  | 0 | 50000 | BEVINS M | 1 | 1 | D | MIKE B |  |  |  |  |  |  |  |  |  |  |  |  |  |  | 0 | 50000 | 5000000 | 100 | 12-035 |  |  |  |  |  |  |  |  |  |  |  |  |  |  |  |  |  |  |  |
| 13417020 |  | Re-survey align network |  | 40d | 2012-05-18 A | 2012-07-16 A | 13411139 FS-55d, 13411137, 13411190, 13411175, 13411135b, 2-02M, 13411195 FS-40d, 13411135ab, 3A-19M FS-20d, 13414100 | 100% |  |  |  |  |  |  | MECH TECH [400 h]; MECH ENG [288 h] | 37,970.56 | 37,970.56 | 0 | 37970.56 | BEVINS M | 1 | 1 | H | MIKE B |  |  | 10-065 |  |  |  |  |  |  |  |  |  |  |  |  |  |  |  | 12-035 |  |  |  |  |  |  |  |  |  |  |  |  |  |  |  |  |  |  |  |
| 13417035 |  | ER - Upstairs |  | 140d | 2012-06-05 A | 2013-03-11 A | 13417026M FS-18d | 100% |  | 2012-06-05 | 2012-12-20 |  |  |  | MECH TECH [1096 h]; MSHOP; MECH ENG [792 h] | 138,305.22 | 106,109.13 | 0 | 136949.28 | BEVINS M | 1 | 1 | S | MIKE B |  |  | 10-065 |  |  |  | 09-012 |  |  |  | 07-024 | DUP | XX | ST |  |  |  |  | 12-035 |  |  |  |  |  |  |  |  | 13417035 |  |  |  |  |  |  |  |  |  |  |
| 13417100M |  | WS - Removed (BIA Activity Complete) | milestone | 0d | 2012-06-05 A | 2012-06-05 A | 2-02M FS+130d | 100% |  | 2012-11-20 | 2012-11-20 |  |  |  |  |  |  |  | 0 | BEVINS M | 1 | 1 | M | MIKE B |  |  |  |  |  |  |  |  |  |  |  |  |  |  |  |  |  |  | 12-035 |  |  |  |  |  |  |  |  | 13417100M | OPC A |  |  |  |  |  |  |  |  |  |
| 13417060 |  | WR - Upstairs FY12 |  | 132d | 2012-06-06 A | 2013-03-11 A | 13417050M FS-50d | 100% |  | 2012-06-06 | 2012-12-11 |  |  |  | MECH ENG [708.64 h]; MECH TECH [1031.42 h]; MSHOP | 124,133.55 | 97,243.16 | 0 | 122977.5016 | BEVINS M | 1 | 1 | S | MIKE B |  |  |  |  |  |  |  |  |  |  |  |  | XX | ST |  |  |  |  | 12-035 |  |  |  |  |  |  |  |  | 13417060 |  | 12-053 |  |  |  |  |  |  |  |  |
| 13417060a |  | WR - Upstairs FY13 |  | 132d | 2012-06-06 A | 2013-03-11 A | 13417060 FS-70d | 100% |  | 2012-06-06 | 2012-12-11 |  |  |  | MECH TECH [80.58 h]; MSHOP; MECH ENG [55.36 h] | 9,766.19 | 7,597.25 | 0 | 9914.2984 | BEVINS M | 1 | 1 | S | MIKE B |  |  |  |  |  |  |  |  |  |  |  |  | XX | ST |  |  |  |  | 12-035 |  |  |  |  |  |  |  |  | 13417060 |  | 12-053 |  |  |  |  |  |  |  |  |
| 13417110 |  | WS - Upstairs |  | 129d | 2012-06-11 A | 2013-03-11 A | 13417100M FS-14d | 100% |  | 2012-06-11 | 2012-12-11 |  |  |  | MECH TECH [1000 h]; MSHOP; MECH ENG [224 h] | 91,341.06 | 61,247.99 | 0 | 92517.95 | BEVINS M | 1 | 1 | S | MIKE B |  |  |  |  |  |  |  |  |  |  |  |  | XX | ST |  |  |  |  | 12-035 |  |  |  |  |  |  |  |  | 13417110 | OPC A |  |  |  |  |  |  |  |  |  |
| 13417026M |  | ER - Removed (BIA Activity Complete) | milestone | 0d | 2012-06-11 A | 2012-06-11 A | 2-02M FS+32d | 100% |  | 2012-07-04 | 2012-07-04 |  |  |  |  |  |  |  | 0 | BEVINS M | 1 | 1 | M | MIKE B |  |  | 10-065 |  |  |  | 09-012 |  |  |  | 07-024 | DUP |  |  |  |  |  |  | 12-035 |  |  |  |  |  |  |  |  | 13417026M |  |  |  |  |  |  |  |  |  |  |
| 13417030 |  | ER - Install stands |  | 117d | 2012-07-02 A | 2012-12-17 A | 13417026M FS-2d | 100% |  | 2012-07-02 | 2012-12-14 |  |  |  | MECH TECH [896 h]; MECH ENG [648 h] | 86,489.88 | 86,502.5 | 0 | 85256 | BEVINS M | 1 | 1 | S | MIKE B |  |  | 10-065 |  |  |  | 09-012 |  |  |  | 07-024 | DUP |  | ST |  |  |  |  | 12-035 |  |  |  |  |  |  |  |  | 13417030 |  |  |  |  |  |  |  |  |  |  |
| 13417085 |  | ES - Upstairs FY12 |  | 104d | 2012-07-16 A | 2013-03-11 A | 13417075M FS-37d | 100% |  | 2012-07-16 | 2012-12-11 |  |  |  | MECH TECH [500.43 h]; MSHOP; MECH ENG [241.87 h] | 54,627.3 | 40,028.75 | 0 | 54025.1836 | BEVINS M | 1 | 1 | S | MIKE B |  |  |  |  |  |  |  |  |  |  |  |  | XX | ST |  |  |  |  | 12-035 |  |  |  |  |  |  |  |  | 13417085 | OPC A | 12-053 |  |  |  |  |  |  |  |  |
| 13417085a |  | ES - Upstairs FY13 |  | 104d | 2012-07-16 A | 2013-03-11 A | 13417085 FS-70d | 100% |  | 2012-07-16 | 2012-12-11 |  |  |  | MECH TECH [459.57 h]; MSHOP; MECH ENG [222.13 h] | 50,602.21 | 36,761.03 | 0 | 51199.407 | BEVINS M | 1 | 1 | S | MIKE B |  |  |  |  |  |  |  |  |  |  |  |  | XX | ST |  |  |  |  | 12-035 |  |  |  |  |  |  |  |  | 13417085 |  | 12-053 |  |  |  |  |  |  |  |  |
| 13417135 |  | TR - Upstairs |  | 93d | 2012-08-13 A | 2013-08-30 A | 13417125M FS-140d | 100% |  | 2012-08-13 | 2012-12-31 |  |  |  | MECH TECH [912 h]; MSHOP; MECH ENG [204 h] | 83,826.15 | 56,358.4 | 6757.3336 | 84466.67 | BEVINS M | 1 | 1 | S | MIKE B |  |  |  |  |  |  |  |  |  |  |  |  | XX | ST |  |  |  |  | 12-035 |  |  |  |  |  |  |  |  | 13417135 | OPC A |  |  |  |  |  |  |  |  |  |
| 13417050M |  | WR - Removed (BIA Activity Complete) | milestone | 0d | 2012-08-13 A | 2012-08-13 A | 2-02M FS+81d | 100% |  | 2012-09-12 | 2012-09-12 |  |  |  |  |  |  |  | 0 | BEVINS M | 1 | 1 | H | MIKE B |  |  |  |  |  |  |  |  |  |  |  |  |  |  |  |  |  |  | 12-035 |  |  |  |  |  |  |  |  | 13417050M |  |  |  |  |  |  |  |  |  |  |
| 13417080 |  | ES - Install stands FY12 |  | 86d | 2012-08-20 A | 2013-03-11 A | 13417075M | 100% |  | 2012-08-20 | 2012-12-20 |  |  |  | MECH TECH [354.46 h]; MECH ENG [160.62 h] | 27,586.95 | 27,692.46 | 0 | 27014.8768 | BEVINS M | 1 | 1 | S | MIKE B |  |  |  |  |  |  |  |  |  |  |  |  | XX | ST |  |  |  |  | 12-035 |  |  |  |  |  |  |  |  | 13417080 | OPC A | 12-053 |  |  |  |  |  |  |  |  |
| 13417080a |  | ES - Install stands FY13 |  | 86d | 2012-08-20 A | 2013-03-11 A | 13417080 FS-70d | 100% |  | 2012-08-20 | 2012-12-20 |  |  |  | MECH TECH [413.54 h]; MECH ENG [187.38 h] | 32,184.21 | 32,307.45 | 0 | 32523.7612 | BEVINS M | 1 | 1 | S | MIKE B |  |  |  |  |  |  |  |  |  |  |  |  | XX | ST |  |  |  |  | 12-035 |  |  |  |  |  |  |  |  | 13417080 |  | 12-053 |  |  |  |  |  |  |  |  |
| 13417075M |  | ES - Removed (BIA Activity Complete) | milestone | 0d | 2012-08-20 A | 2012-08-20 A | 2-02M FS+85d | 100% |  | 2012-09-18 | 2012-09-18 |  |  |  |  |  |  |  | 0 | BEVINS M | 1 | 1 | M | MIKE B |  |  |  |  |  |  |  |  |  |  |  |  |  |  |  |  |  |  | 12-035 |  |  |  |  |  |  |  |  | 13417075M |  |  |  |  |  |  |  |  |  |  |
| 13417040 |  | ER - Install magnets and girders FY12 |  | 82d | 2012-09-10 A | 2013-05-13 A | 13417030 FS-30d | 100% |  | 2012-09-10 | 2013-01-11 |  |  |  | MECH TECH [242.53 h]; MECH ENG [68.68 h] | 16,000.97 | 16,047.09 | 0 | 15593.8748 | BEVINS M | 1 | 1 | S | MIKE B |  |  | 10-065 |  |  | 08-016 | 09-012 |  |  |  |  |  | XX | ST |  |  |  |  | 12-035 |  |  |  |  |  |  |  |  | 13417040 | OPC A | 12-053 |  |  |  |  |  |  |  |  |
| 13417040a |  | ER - Install magnets and girders FY13 |  | 82d | 2012-09-10 A | 2013-05-13 A | 13417040 FS-70d | 100% |  | 2012-09-10 | 2013-01-11 |  |  |  | MECH ENG [511.32 h]; MECH TECH [1805.47 h] | 119,119.47 | 119,462.81 | 0 | 119797.9694 | BEVINS M | 1 | 1 | S | MIKE B |  |  | 10-065 |  |  | 08-016 | 09-012 |  |  |  |  |  | XX | ST |  |  |  |  | 12-035 |  |  |  |  |  |  |  |  | 13417040 |  | 12-053 |  |  |  |  |  |  |  |  |
| 13417055 |  | WR - Install stands |  | 82d | 2012-09-10 A | 2013-04-13 A | 13447035 FS-50d | 100% |  | 2012-09-10 | 2013-01-11 |  |  |  | MECH TECH [936 h]; MECH ENG [208 h] | 57,647.48 | 57,790.14 | 0 | 57975.84 | BEVINS M | 1 | 1 | S | MIKE B |  |  |  |  |  |  |  |  |  |  |  |  | XX | ST |  |  |  |  | 12-035 |  |  |  |  |  |  |  |  | 13417055 | OPC A |  |  |  |  |  |  |  |  |  |
| 13417105 |  | WS - Install stands |  | 50d | 2012-10-01 A | 2013-08-09 A | 13417100M | 100% |  | 2012-10-01 | 2012-12-11 |  |  |  | MECH ENG [168 h]; MECH TECH [752 h] | 46,643.2 | 46,643.2 | 5597.184 | 46643.2 | BEVINS M | 1 | 1 | S | MIKE B |  |  |  |  |  |  |  |  |  |  |  |  | XX | ST |  |  |  |  | 12-035 |  |  |  |  |  |  |  |  | 13417105 | OPC A |  |  |  |  |  |  |  |  |  |
| 13417160 |  | LCW Hoses FY13 |  | 120d | 2012-10-01 A | 2013-02-11 A | 13417155, 9-130M FS+22d | 100% |  | 2012-10-01 | 2013-03-29 |  |  |  | PROCUREMENT<$50K 60; PROCUREMENT>$50K 69 | 160,000 |  | 0 | 160000 | BEVINS M | 1 | 1 | D | MIKE B |  |  |  |  |  |  |  |  |  |  |  |  |  |  | 0 | 160000 | 16000000 | 100 | 12-035 |  |  | Split |  |  |  |  | 13-003 |  | OPC A |  |  |  |  |  |  |  |  |  |
| 13417170 |  | Material handling/tooling/transporation FY13 |  | 228d | 2012-10-01 A | 2013-08-30 A | 13417165 | 100% |  |  |  |  |  |  | PROCUREMENT<$50K 60 | 36,116.5 |  | 5417.475 | 36116.5 | BEVINS M | 1 | 1 | D | MIKE B |  |  |  |  |  |  |  |  |  |  |  |  |  |  | 0 | 36116.5 | 3611650 | 100 | 12-035 |  |  |  |  |  |  |  |  |  | OPC A |  |  |  |  |  |  |  |  |  |
| 13417090 |  | ES - Install magnets & girders |  | 122d | 2012-11-12 A | 2013-07-15 A | 13417085a FS-60d, 13417080a FS-20d | 100% |  | 2012-11-12 | 2013-05-14 |  |  |  | MECH TECH [1528 h]; MECH ENG [344 h] | 94,965.92 | 94,965.92 | 0 | 94965.92 | BEVINS M | 1 | 1 | S | MIKE B |  |  |  |  |  |  |  |  |  |  |  |  |  | ST |  |  |  |  | 12-035 |  |  |  |  |  |  |  |  | 13417090 | OPC A |  |  |  |  |  |  |  |  |  |
| 13417115 |  | WS - Install magnets and girders |  | 86d | 2013-01-11 A | 2013-08-30 A | 13417105 FS-15d, 13417110 FS-35d | 100% |  | 2013-01-11 | 2013-05-14 |  |  |  | MECH TECH [1544 h]; MECH ENG [344 h] | 95,699.68 | 95,699.68 | 4784.984 | 95699.68 | BEVINS M | 1 | 1 | S | MIKE B |  |  |  |  |  |  |  |  |  |  |  |  |  | ST |  |  |  |  | 12-035 |  |  |  |  |  |  |  |  | 13417115 | OPC A |  |  |  |  |  |  |  |  |  |
| 13417065 |  | WR - Install magnets & girders |  | 65d | 2013-01-14 A | 2013-08-16 A | 13417060a FS-40d, 13417055 FS-20d | 100% |  | 2013-01-14 | 2013-04-16 |  |  |  | MECH TECH [2104 h]; MECH ENG [472 h] | 130,643.36 | 130,643.36 | 6532.168 | 130643.36 | BEVINS M | 1 | 1 | S | MIKE B |  |  |  |  |  |  |  |  |  |  |  |  |  | ST |  |  |  |  | 12-035 |  |  |  |  |  |  |  |  | 13417065 | OPC A |  |  |  |  |  |  |  |  |  |
| 13417130 |  | TR - Install stands |  | 22d | 2013-02-01 A | 2013-08-30 A | 13417125M FS-10d | 100% |  | 2013-03-12 | 2013-04-10 |  |  |  | MECH TECH [752 h]; MECH ENG [168 h] | 46,643.2 | 46,643.2 | 5597.184 | 46643.2 | BEVINS M | 1 | 1 | S | MIKE B |  |  |  |  |  |  |  |  |  |  |  |  |  | ST |  |  |  |  | 12-035 |  |  |  |  |  |  |  |  | 13417130 | OPC A |  |  |  |  |  |  |  |  |  |
| 13417140 |  | TR - Install magnets and girders |  | 47d | 2013-03-04 A | 2013-08-30 A | 13417130 FS-25d, 13417135 FS-25d | 100% |  | 2013-05-01 | 2013-07-08 |  |  |  | MECH TECH [1536 h]; MECH ENG [344 h] | 95,332.8 | 95,332.8 | 19066.56 | 95332.8 | BEVINS M | 1 | 1 | S | MIKE B |  |  |  |  |  |  |  |  |  |  |  |  |  | ST |  |  |  |  | 12-035 |  |  |  |  |  |  |  |  | 13417140 | OPC A |  |  |  |  |  |  |  |  |  |
| 13417125M |  | TR - Removed (BIA Activity Complete) | milestone | 0d | 2013-03-11 A | 2013-03-11 A | 2-02M FS+199d | 100% |  | 2013-04-01 | 2013-04-01 |  |  |  |  |  |  |  | 0 | BEVINS M | 1 | 1 | M | MIKE B |  |  |  |  |  |  |  |  |  |  |  |  |  |  |  |  |  |  | 12-035 |  |  |  |  |  |  |  |  | 13417125M | OPC A |  |  |  |  |  |  |  |  |  |
| 13417045 |  | ER - Final align |  | 8d | 2013-06-03 A | 2013-07-15 A | 13417160, 13417040a | 100% |  | 2013-07-23 | 2013-08-01 |  |  |  | MECH TECH [304 h]; MECH ENG [68 h] | 18,861.92 | 18,861.92 | 0 | 18861.92 | BEVINS M | 1 | 1 | H | MIKE B |  |  |  |  |  |  |  |  |  |  |  |  |  |  |  |  |  |  | 12-035 |  |  |  |  |  |  |  | 13-003 | 13417045 | OPC A |  |  |  |  |  |  |  |  |  |
| 13417095 |  | ES - Final align |  | 5d | 2013-07-08 A | 2013-08-07 A | 13417090, 13436065 | 100% |  | 2013-08-08 | 2013-08-14 |  |  |  | MECH TECH [200 h]; MECH ENG [44 h] | 12,355.84 | 12,355.84 | 6177.92 | 12355.84 | BEVINS M | 1 | 1 | H | MIKE B |  |  |  |  |  |  |  |  |  |  |  |  |  |  |  |  |  |  | 12-035 |  |  |  |  |  |  |  |  | 13417095 | OPC A |  |  |  |  |  |  |  |  |  |
| 13417070 |  | WR - Final align |  | 8d | 2013-08-01 A | 2013-08-26 A | 13417065, 13427062 | 100% |  | 2013-09-03 | 2013-09-12 |  |  |  | MECH TECH [320 h]; MECH ENG [72 h] | 19,885.12 | 19,885.12 | 19885.12 | 19885.12 | BEVINS M | 1 | 1 | H | MIKE B |  |  |  |  |  |  |  |  |  |  |  |  |  |  |  |  |  |  | 12-035 |  |  |  |  |  |  |  |  | 13417070 | OPC A |  |  |  |  |  |  |  |  |  |
| 13417120 |  | WS - Final align |  | 5d | 2013-08-12 A | 2013-08-30 A | 13417115, 13436060 | 100% |  | 2013-08-12 | 2013-08-16 |  |  |  | MECH TECH [200 h]; MECH ENG [44 h] | 12,355.84 | 12,355.84 | 12355.84 | 12355.84 | BEVINS M | 1 | 1 | H | MIKE B |  |  |  |  |  |  |  |  |  |  |  |  |  |  |  |  |  |  | 12-035 |  |  |  |  |  |  |  |  | 13417120 | OPC A |  |  |  |  |  |  |  |  |  |
| 13417145 |  | TR - Final align |  | 4d | 2013-08-30 A | 2013-08-30 A | 13417140 | 100% |  | 2013-10-01 | 2013-10-04 |  |  |  | MECH TECH [100 h]; MECH ENG [24 h] | 6,524.08 | 6,322.64 | 6322.64 | 6322.64 | BEVINS M | 1 | 1 | H | MIKE B |  |  |  |  |  |  |  |  |  |  |  |  |  |  |  |  |  |  | 12-035 |  |  |  |  |  |  |  |  | 13417145 | OPC A |  |  |  |  |  |  |  |  |  |
| 13417150 |  | Alignment complete |  | 3d | 2013-08-30 A | 2013-08-30 A | 13456029, 13417145, 13427032, 13427061, 13456030M | 100% |  | 2013-11-04 | 2013-11-06 |  |  |  | MECH TECH [60 h]; MECH ENG [12 h] | 3,735.24 | 3,619.92 | 3619.92 | 3619.92 | BEVINS M | 1 | 1 | H | MIKE B |  |  |  |  |  |  |  |  |  |  |  |  |  |  |  |  |  |  | 12-035 |  |  |  |  |  |  |  |  |  | OPC A |  |  |  |  |  |  |  |  |  |
| 13417175 |  | Re-Baseline Actuals Adjustment |  | 1d | 2013-08-30 A | 2013-08-30 A |  | 100% |  | 2013-09-03 | 2013-09-03 |  |  |  | PROCUREMENT>$50K 69 NO ESCALATION | 1,070,381.23 |  |  | 1070381.23 |  |  |  |  |  |  |  |  |  |  |  |  |  |  |  |  |  |  |  | 0 | 1070381.23 | 107038123 | 100 |  |  |  |  | ADJ |  |  |  |  |  |  |  |  |  |  |  |  |  |  |  |
| 23417065 |  | WR - Install magnets & girders |  | 20d | 2013-09-03 A | 2013-09-23 A | 9-130M FS+228d | 100% |  | 2013-10-01 | 2013-10-28 |  |  | 8/5 M-F w/JLAB Holidays ReBaseline | MECH TECH [118.2 h]; MECH ENG [28.34 h] | 7,709.4 | 7,471.36 |  | 0 | BEVINS M | 1 | 1 | H | MIKE B |  |  |  |  |  |  |  |  |  |  |  |  |  |  |  |  |  |  | 12-035 |  |  |  |  |  |  |  |  |  |  |  | 23417065 | 7471.354911 | PE | 13-015 | PR |  |  |  |
| 23417115 |  | WS - Install magnets and girders |  | 11d | 2013-09-03 A | 2013-09-23 A | 9-130M FS+228d | 100% |  | 2013-10-01 | 2013-10-15 |  |  | 8/5 M-F w/JLAB Holidays ReBaseline | MECH TECH [153.07 h]; MECH ENG [36 h] | 9,931.38 | 9,624.74 |  | 0 | BEVINS M | 1 | 1 | H | MIKE B |  |  |  |  |  |  |  |  |  |  |  |  |  |  |  |  |  |  | 12-035 |  |  |  |  |  |  |  |  |  |  |  | 23417115 | 9624.740104 | PE | 13-015 | PR |  |  |  |
| 23417120 |  | WS - Final align |  | 13d | 2013-09-03 A | 2013-09-23 A | 23417115 FS-11d | 100% |  | 2013-10-01 | 2013-10-17 |  |  | 8/5 M-F w/JLAB Holidays ReBaseline | MECH TECH [211.2 h]; MECH ENG [52.8 h] | 13,936.56 | 13,506.24 |  | 0 | BEVINS M | 1 | 1 | S | MIKE B |  |  |  |  |  |  |  |  |  |  |  |  |  | ST |  |  |  |  | 12-035 |  |  |  |  |  |  |  |  |  |  |  | 23417120 | 13506.24 | PE | 13-015 | PR |  |  |  |
| 23417130 |  | TR - Install stands |  | 16d | 2013-09-03 A | 2013-11-22 | 9-130M FS+228d | 85% | 16d | 2013-10-01 | 2013-10-22 | 23d | 0d | 8/5 M-F w/JLAB Holidays ReBaseline | MECH TECH [280.8 h]; MECH ENG [70.2 h] | 18,529.29 | 9,976.2 |  | 3591.432 | BEVINS M | 1 | 1 | S | MIKE B |  |  |  |  |  |  |  |  |  |  |  |  |  | ST |  |  |  |  | 12-035 |  |  |  |  |  |  |  |  |  |  |  | 23417130 | 11672.154 | PE | 13-015 | PR |  |  |  |
| 23417140 |  | TR - Install magnets and girders FY13 |  | 21d | 2013-09-03 A | 2013-11-22 | 23417130 FS-16d | 95% | 16d | 2013-10-01 | 2013-10-29 | 23d | 4d | 8/5 M-F w/JLAB Holidays ReBaseline | MECH TECH [616.32 h]; MECH ENG [148.8 h] | 40,275.16 | 28,931.53 |  | 7806.32064 | BEVINS M | 1 | 1 | S | MIKE B |  |  |  |  |  |  |  |  |  |  |  |  |  | ST |  |  |  |  | 12-035 |  |  |  |  |  |  |  |  |  |  |  | 23417140 | 29273.7024 | PE | 13-015 | PR |  |  |  |
| 23417140a |  | TR - Install magnets and girders FY14 |  | 1d | 2013-09-03 A | 2013-11-22 | 23417140 FS-25d | 95% | 16d | 2013-10-01 | 2013-10-01 | 23d | 4d | 8/5 M-F w/JLAB Holidays ReBaseline | MECH TECH [30.82 h]; MECH ENG [7.44 h] | 2,013.97 | 1,446.72 |  | 402.7936956 | BEVINS M | 1 | 1 | S | MIKE B |  |  |  |  |  |  |  |  |  |  |  |  |  | ST |  |  |  |  | 12-035 |  |  |  |  |  |  |  |  |  |  |  | 23417140 | 1510.4763585 | PE | 13-015 | PR | 14-001 |  |  |
| 23417165 |  | Procure S/R plumbing materials |  | 20d | 2013-09-03 A | 2013-10-21 A | 9-130M FS+228d | 100% |  | 2013-10-01 | 2013-10-28 |  |  | 8/5 M-F w/JLAB Holidays ReBaseline | SUPPLIES & MATERIALS | 12,255 |  |  | 3063.75 | BEVINS M | 1 | 1 | D | MIKE B |  |  |  |  |  |  |  |  |  |  |  |  |  |  |  |  |  |  | 12-035 |  |  |  |  |  |  |  | 13-003 |  |  |  | 23417165 | 9191.25 |  | 13-015 | PR |  | PE |  |
| 23417170 |  | Procure S/R Vacuum materials |  | 20d | 2013-09-03 A | 2013-09-23 A | 9-130M FS+228d | 100% |  | 2013-10-01 | 2013-10-28 |  |  | 8/5 M-F w/JLAB Holidays ReBaseline | PROCUREMENT<$50K 60 | 9,830.9 |  |  | 0 | BEVINS M | 1 | 1 | D | MIKE B |  |  |  |  |  |  |  |  |  |  |  |  |  |  | 0 | 9830.9 | 983090 | 100 | 12-035 |  |  |  |  |  |  |  | 13-003 |  |  |  | 23417165 | 9830.9 |  | 13-015 | PR |  | PE | OB |
| 23417145 |  | TR - Final align FY13 |  | 1d | 2013-10-21 A | 2013-11-27 | 23417140 FS-20d, 23417140a FS-20d | 50% | 19d | 2013-11-21 | 2013-11-21 | 19d | 0d | 8/5 M-F w/JLAB Holidays ReBaseline | MECH TECH [9.09 h]; MECH ENG [2.27 h] | 599.69 | 192.76 |  | 290.5888 | BEVINS M | 1 | 1 | S | MIKE B |  |  |  |  |  |  |  |  |  |  |  |  |  | ST |  |  |  |  | 12-035 |  |  |  |  |  |  |  |  |  |  |  | 23417145 |  | PE | 13-015 | PR |  |  |  |
| 23417145a |  | TR - Final align FY14 |  | 4d | 2013-10-21 A | 2013-11-27 | 23417145 FS-20d, 23417140a FS-20d | 50% | 19d | 2013-11-22 | 2013-11-27 | 19d | 0d | 8/5 M-F w/JLAB Holidays ReBaseline | MECH TECH [190.91 h]; MECH ENG [47.73 h] | 12,597.81 | 4,049.29 |  | 6298.9028 | BEVINS M | 1 | 1 | S | MIKE B |  |  |  |  |  |  |  |  |  |  |  |  |  | ST |  |  |  |  | 12-035 |  |  |  |  |  |  |  |  |  |  |  | 23417145 |  | PE | 13-015 | PR | 14-001 |  |  |
| 23417150 |  | Alignment complete |  | 3d | 2013-12-10 | 2013-12-12 | 23417145 FS+6d, 23417145a FS+6d |  |  |  |  | 79d | 17d | 8/5 M-F w/JLAB Holidays ReBaseline | MECH TECH [64 h]; MECH ENG [16 h] | 4,223.2 |  |  | 0 | BEVINS M | 1 | 1 | H | MIKE B |  |  |  |  |  |  |  |  |  |  |  |  |  |  |  |  |  |  | 12-035 |  |  |  |  |  |  |  |  |  |  |  | 23417150 |  | PE | 13-015 | PR | 14-001 |  |  |

Notes:
- 13416025: Steps: East Spreader (done); East Recombiner (done); West Spreader (done); West Recombiner (done); Transport Recombiner (done)
- 13417035: Steps: Disassemble dipoles Part 1 (done); Disassemble dipoles Part 2 (done); Disassemble dipoles Part 3 (done); Disassemble BCOM dipoles (done); Reassemble dipoles Part 1 (done); Reassemble dipoles Part 2 (done); Reassemble dipoles Part 3 (done); Resassemble BCOM dipoles (done); Machine Dipoles Part 1 (done); Machine Dipoles Part 2 (done); Machine Dipoles Part 3 (done); Machine BCOM dipoles (done); Measure Dipoles Part 1 (done); Measure Dipoles Part 2 (done); Measure Dipoles Part 3 (done); Measure BCOM dipoles (done); Rebuild Girders Part 1 (done); Rebuild Girders Part 2 (done); Machine Girders Part 1 (done)
- 13417060: Steps: Disassemble dipoles Part 1 (done); Disassemble dipoles Part 2 (done); Disassemble dipoles Part 3 (done); Disassemble BCOM dipoles (done); Reassemble dipoles Part 1 (done); Reassemble dipoles Part 2 (done); Reassemble dipoles Part 3 (done); Resassemble BCOM dipoles (done); Machine Dipoles Part 1 (done); Machine Dipoles Part 2 (done); Machine Dipoles Part 3 (done); Machine BCOM dipoles (done); Measure Dipoles Part 1 (done); Measure Dipoles Part 2 (done); Measure Dipoles Part 3 (done); Measure BCOM dipoles (done); Rebuild Girders Part 1 (done); Rebuild Girders Part 2 (done); Machine Girders Part 1 (done)
- 13417060a: Steps: Disassemble dipoles Part 1 (done); Disassemble dipoles Part 2 (done); Disassemble dipoles Part 3 (done); Disassemble BCOM dipoles (done); Reassemble dipoles Part 1 (done); Reassemble dipoles Part 2 (done); Reassemble dipoles Part 3 (done); Resassemble BCOM dipoles (done); Machine Dipoles Part 1 (done); Machine Dipoles Part 2 (done); Machine Dipoles Part 3 (done); Machine BCOM dipoles (done); Measure Dipoles Part 1 (done); Measure Dipoles Part 2 (done); Measure Dipoles Part 3 (done); Measure BCOM dipoles (done); Rebuild Girders Part 1 (done); Rebuild Girders Part 2 (done); Machine Girders Part 1 (done)
- 13417110: Steps: Disassemble dipoles Part 1 (done); Disassemble dipoles Part 2 (done); Disassemble dipoles Part 3 (done); Disassemble BCOM dipoles (done); Reassemble dipoles Part 1 (done); Reassemble dipoles Part 2 (done); Reassemble dipoles Part 3 (done); Resassemble BCOM dipoles (done); Machine Dipoles Part 1 (done); Machine Dipoles Part 2 (done); Machine Dipoles Part 3 (done); Machine BCOM dipoles (done); Measure Dipoles Part 1 (done); Measure Dipoles Part 2 (done); Measure Dipoles Part 3 (done); Measure BCOM dipoles (done); Rebuild Girders Part 1 (done); Rebuild Girders Part 2 (done); Machine Girders Part 1 (done)
- 13417030: Steps: Mark bolts (done); Install floor/ceiling plates (done); Grout floor plates (done); Install stands Part 1 (done); Install stands Part 2 (done); Install stands Part 3 (done); Install pedestals (done); Align stands Part 1 (done); Align stands Part 2 (done); Align pedestals (done); Install LCW/Inst air Part 1Copper (done); Install LCW/Inst air Part 2 Copper (done); Mount shunt resistors (done); Install LCW/Inst air Hoses (done)
- 13417085: Steps: Disassemble dipoles Part 1 (done); Disassemble dipoles Part 2 (done); Disassemble dipoles Part 3 (done); Disassemble BCOM dipoles (done); Reassemble dipoles Part 1 (done); Reassemble dipoles Part 2 (done); Reassemble dipoles Part 3 (done); Resassemble BCOM dipoles (done); Machine Dipoles Part 1 (done); Machine Dipoles Part 2 (done); Machine Dipoles Part 3 (done); Machine BCOM dipoles (done); Measure Dipoles Part 1 (done); Measure Dipoles Part 2 (done); Measure Dipoles Part 3 (done); Measure BCOM dipoles (done); Rebuild Girders Part 1 (done); Rebuild Girders Part 2 (done); Machine Girders Part 1 (done)
- 13417085a: Steps: Disassemble dipoles Part 1 (done); Disassemble dipoles Part 2 (done); Disassemble dipoles Part 3 (done); Disassemble BCOM dipoles (done); Reassemble dipoles Part 1 (done); Reassemble dipoles Part 2 (done); Reassemble dipoles Part 3 (done); Resassemble BCOM dipoles (done); Machine Dipoles Part 1 (done); Machine Dipoles Part 2 (done); Machine Dipoles Part 3 (done); Machine BCOM dipoles (done); Measure Dipoles Part 1 (done); Measure Dipoles Part 2 (done); Measure Dipoles Part 3 (done); Measure BCOM dipoles (done); Rebuild Girders Part 1 (done); Rebuild Girders Part 2 (done); Machine Girders Part 1 (done)
- 13417135: Steps: Disassemble dipoles Part 1 (done); Disassemble dipoles Part 2 (done); Disassemble dipoles Part 3 (done); Disassemble BCOM dipoles (done); Reassemble dipoles Part 1 (done); Reassemble dipoles Part 2 (done); Reassemble dipoles Part 3 (done); Resassemble BCOM dipoles (done); Machine Dipoles Part 1 (done); Machine Dipoles Part 2 (done); Machine Dipoles Part 3 (done); Machine BCOM dipoles (done); Measure Dipoles Part 1 (done); Measure Dipoles Part 2 (done); Measure Dipoles Part 3 (done); Measure BCOM dipoles (done); Rebuild Girders Part 1 (done); Rebuild Girders Part 2 (done); Machine Girders Part 1 (done)
- 13417080: Steps: Mark bolts (done); Install floor/ceiling plates (done); Grout floor plates (done); Install stands Part 1 (done); Install stands Part 2 (done); Install stands Part 3 (done); Install pedestals (done); Align stands Part 1 (done); Align stands Part 2 (done); Align pedestals (done); Install LCW/Inst air Part 1 (done); Install LCW/Inst air Part 2 (done); Mount shunt resistors (done)
- 13417080a: Steps: Mark bolts (done); Install floor/ceiling plates (done); Grout floor plates (done); Install stands Part 1 (done); Install stands Part 2 (done); Install stands Part 3 (done); Install pedestals (done); Align stands Part 1 (done); Align stands Part 2 (done); Align pedestals (done); Install LCW/Inst air Part 1 (done); Install LCW/Inst air Part 2 (done); Mount shunt resistors (done)
- 13417040: Steps: Install Dipoles Part 1 (done); Install Dipoles Part 2 (done); Install Dipoles Part 3 (done); Install BCOMS (done); Install Girders Part 1 (done); Install Girders Part 2 (done); Align for hookup Part 1 (done); Align for hookup Part 2 (done); Vacuum hookup & leak check Part 1 (done); Vacuum hookup & leak check Part 2 (done); LCW hookup (done)
- 13417040a: Steps: Install Dipoles Part 1 (done); Install Dipoles Part 2 (done); Install Dipoles Part 3 (done); Install BCOMS (done); Install Girders Part 1 (done); Install Girders Part 2 (done); Align for hookup Part 1 (done); Align for hookup Part 2 (done); Vacuum hookup & leak check Part 1 (done); Vacuum hookup & leak check Part 2 (done); LCW hookup (done)
- 13417055: Steps: Mark bolts (done); Install floor/ceiling plates (done); Grout floor plates (done); Install stands Part 1 (done); Install stands Part 2 (done); Install stands Part 3 (done); Install pedestals (done); Align stands Part 1 (done); Align stands Part 2 (done); Align pedestals (done); Install LCW/Inst air Part 1 (done); Install LCW/Inst air Part 2 (done); Mount shunt resistors (done)
- 13417105: Steps: Mark bolts (done); Install floor/ceiling plates (done); Grout floor plates (done); Install stands Part 1 (done); Install stands Part 2 (done); Install stands Part 3 (done); Install pedestals (done); Align stands Part 1 (done); Align stands Part 2 (done); Align pedestals (done); Install LCW/Inst air Part 1 (done); Install LCW/Inst air Part 2 (done); Mount shunt resistors (done)
- 13417090: Steps: Install Dipoles Part 1 (done); Install Dipoles Part 2 (done); Install Dipoles Part 3 (done); Install BCOMS1 (done); Install Girders Part 1 (done); Install Girders Part 2 (done); Align for Hookup Part 1 (done); Align for Hookup Part 2 (done); Vacuum hookup and leak check part 1 (done); Vacuum hookup and leak check part 2 (done)
- 13417115: Steps: Install Dipoles Part 1 (done); Install Dipoles Part 2 (done); Install Dipoles Part 3 (done); Install BCOMS (done); Install Girders Part 1 (done); Install Girders Part 2 (done); Align for Hook-up Part 1 (done); Align for Hook-up Part 2 (done); Vacuum Hook-up and Leak Check Part 1 (done); Vacuum Hook-up and Leak Check Part 2 (done); LCW Hook-up (done)
- 13417065: Steps: Install Dipoles Part 1 (done); Install Dipoles Part 2 (done); Install Dipoles Part 3 (done); Install BCOMS (done); Install Girders Part 1 (done); Install Girders Part 2 (done); Align for Hook-up Part 1 (done); Align for Hook-up Part 2 (done); Vacuum Hook-up and Leak Check Part 1 (done); Vacuum Hook-up and Leak Check Part 2 (done); LCW Hook-up (done)
- 13417130: Steps: Mark bolts (done); Install floor/ceiling plates (done); Grout floor plates (done); Install stands Part 1 (done); Install stands Part 2 (done); Install stands Part 3 (done); Install pedestals (done); Align stands Part 1 (done); Align stands Part 2 (done); Align pedestals (done); Install LCW/Inst air Part 1 (done); Install LCW/Inst air Part 2 (done); Mount shunt resistors (done)
- 13417140: Steps: Install Dipoles Part 1 (done); Install Dipoles Part 2 (done); Install Dipoles Part 3 (done); Install BCOMS (done); Install Girders Part 1 (done); Install Girders Part 2 (done); Align for Hook-up Part 1 (done); Align for Hook-up Part 2 (done); Vacuum Hook-up and Leak Check Part 1 (done); Vacuum Hook-up and Leak Check Part 2 (done); LCW Hook-up (done)
- 23417120: Steps: Align dipoles and girders (done); Align beampipes (done)
- 23417130: Steps: Install AT line peds (done); Align & grout AT line peds (done); Install LCW for 2T line (done); Install Air manifolds; Install LCW hoses (done)
- 23417140: Steps: Install ZA septa (done); Install AT line girders (done); Align for hookup (done); Beampipe fabrication (done); Vacuum hookup (done); Final vacuum leakcheck
- 23417140a: Steps: Install ZA septa (done); Install AT line girders (done); Align for hookup (done); Beampipe fabrication (done); Vacuum hookup (done); Final vacuum leakcheck
- 23417145: Steps: Align Matching Section (done); Align septa, dipoles and girders; Align beampipes
- 23417145a: Steps: Align Matching Section (done); Align septa, dipoles and girders; Align beampipes

| ID | WBS | Activity | Type | Duration | Start | Finish | Predecessors | Complete | Planned start | Planned finish | Resources | Cost | Actual cost | LOE Divider | LOE Multiplier | Calculated Remaining Total Cost | MONTHLY EV COST | RESP - Responsibility | STRT%COMP for CM EVM | FNSH%COMP for CM EVM | EVMS Reporting Codes | CAM RESPONSIBLE | CR 08-029 | CR 08-058 | CR 10-065 | Activities with Steps | CR 09-012 | CR 10-003 | CR 11-001 | Milestone Level | CR 09-034 | CR 07-024 | Advance Purchase Plan > 500K | CR 08-016 | CR 08-010 | 12 GEV MAJOR PROCUREMENT CATAGORY | CR 10-030 | Remaining Material Cost Based on % Compl | Claimed Material Cost Based on % Complet | Initial Claimed Material Calc | Claimed Material Divider | LOE % Pre Calc | LOE % | ReBaseline Actuals Adjustment |
| --- | --- | --- | --- | --- | --- | --- | --- | --- | --- | --- | --- | --- | --- | --- | --- | --- | --- | --- | --- | --- | --- | --- | --- | --- | --- | --- | --- | --- | --- | --- | --- | --- | --- | --- | --- | --- | --- | --- | --- | --- | --- | --- | --- | --- |
|  | 2 | **1.3.4.2 EXISTING ARCS (1-9, A, B, & C)** |  |  | 2009-01-02 | 2013-11-27 |  |  |  |  |  |  |  |  |  |  |  |  |  |  |  |  |  |  |  |  |  |  |  |  |  |  |  |  |  |  |  |  |  |  |  |  |  |  |
|  | 1 | **1.3.4.2.1 DIPOLES** |  |  | 2009-01-02 | 2013-08-30 |  |  |  |  |  |  |  |  |  |  |  |  |  |  |  |  |  |  |  |  |  |  |  |  |  |  |  |  |  |  |  |  |  |  |  |  |  |  |
| 13421909LOE |  | FY09 Mngmnt & Oversight (EXIST ARC Dipoles) |  | 189d | 2009-01-02 A | 2009-09-30 A | 13421909LOEXD | 100% |  |  | SR STAFF [213.39 h]; TRAVEL | 39,529.9 | 21,945.03 | 100 | 100 | 0 | 39529.893475 | BEVINS M | 1 | 1 | E | MIKE B | 08-029 | 08-058 |  |  |  |  |  |  |  |  |  |  |  |  |  |  |  |  |  |  |  |  |
| 13421025 |  | Prcrmnt Prep for New Hall A&C Dipoles |  | 94d | 2009-03-16 A | 2009-07-27 A | 9-090M | 100% |  |  | MECH DES [40 h]; MECH ENG [44 h] | 4,561.24 | 4,561.24 |  |  | 0 | 4561.24 | BEVINS M | 1 | 1 | H | MIKE B | 08-029 |  | 10-065 |  |  |  |  |  |  |  |  |  |  |  |  |  |  |  |  |  |  |  |
| 13421030 |  | Vendor Fab New Hall A&C Dipoles Original Labor FY10 |  | 18d | 2009-07-01 A | 2009-07-27 A | 13421025 | 100% |  |  | MECH ENG [170.25 h]; MECH DES [73.88 h] | 14,102.55 | 14,102.55 |  |  | 0 | 14458.551751 | BEVINS M | 1 | 1 | H | MIKE B | 08-029 |  | 10-065 | NB | 09-012 | 10-003 | 11-001 |  |  |  |  |  |  |  |  |  |  |  |  |  |  |  |
| 13421030a |  | Vendor Fab New Hall A&C Dipoles Original Labor FY11 |  | 18d | 2009-07-01 A | 2009-07-27 A | 13421030, 13421025 | 100% |  |  | MECH ENG [41.75 h]; MECH DES [18.12 h] | 3,458.45 | 3,458.45 |  |  | 0 | 3682.7541 | BEVINS M | 1 | 1 | H | MIKE B | 08-029 |  | 10-065 | NB | 09-012 | 10-003 | 11-001 |  |  |  |  |  |  |  |  |  |  |  |  |  |  |  |
| 13421050M |  | Delivery Complete for Magnet Steel & Conductor (EXIST ARC DIPOLES) | milestone | 0d | 2009-07-27 A | 2009-07-27 A | 13411100M, 13411120M, 13411080M, 13451060M, 13422040M FS-25d | 100% | 2009-09-29 | 2009-09-29 |  |  |  |  |  |  | 0 | BEVINS M | 1 | 1 | M | MIKE B | 08-029 |  |  |  |  |  |  | 6 | 09-034 |  |  |  |  |  |  |  |  |  |  |  |  |  |
| 13421055 |  | Prcrmnt Prep for H Steel (EXIST ARC Dipoles) |  | 99d | 2009-08-25 A | 2010-01-22 A | 13411055 FS-110d, 121421021 FS-500d, 121421020 FS-500d, 121425015 FS-500d | 100% |  |  | MECH ENG [40 h]; MECH DES [20 h] | 3,510.02 | 3,510.02 |  |  | 0 | 3538.8 | BEVINS M | 1 | 1 | H | MIKE B | 08-029 |  | 10-065 |  |  |  |  |  |  |  |  |  |  |  |  |  |  |  |  |  |  |  |
| 13421910LOE |  | FY10 Mngmnt & Oversight (EXIST ARC Dipoles) |  | 248d | 2009-10-01 A | 2010-09-30 A | 13421909LOE, 13444909LOE | 100% |  |  | TRAVEL; SR STAFF [320 h] | 57,769.07 | 33,958.4 | 100 | 100 | 0 | 57769.069421 | BEVINS M | 1 | 1 | E | MIKE B | 08-029 |  |  |  |  |  |  |  |  |  |  |  |  |  |  |  |  |  |  |  |  |  |
| 13421046 |  | Fabrication of Existing Arc Dipole Rebuild Parts (Procurement Prep) |  | 181d | 2009-11-02 A | 2010-07-28 A | 9-090M FS+65d | 100% |  |  | MECH DES [21 h]; MECH TECH [72 h]; MECH ENG [72 h] | 8,696.52 | 8,696.52 |  |  | 0 | 8427.36 | BEVINS M | 1 | 1 | H | MIKE B | 08-029 |  |  |  | 09-012 |  |  |  | 09-034 | 07-024 | APP | 08-016 |  |  |  |  |  |  |  |  |  |  |
| 13421060M |  | Award Contract for H Steel (EXIST ARC DIPOLES) | milestone | 0d | 2010-01-22 A | 2010-01-22 A | 13421055 | 100% | 2010-02-24 | 2010-02-24 |  |  |  |  |  |  | 0 | BEVINS M | 1 | 1 | M | MIKE B | 08-029 |  | 10-065 |  |  |  |  | 6 |  |  |  |  |  |  |  |  |  |  |  |  |  |  |
| 13421065 |  | P-1 Vend Fab H Steel (EXIST ARC Dipoles) Labor FY10 |  | 321.71d | 2010-03-15 A | 2011-06-27 A | 13421060M | 100% |  |  | MECH ENG [21.94 h]; MECH DES [21.94 h] | 2,480.94 | 2,480.94 |  |  | 0 | 2437.3146 | BEVINS M | 1 | 1 | D | MIKE B | 08-029 |  | 10-065 |  | 09-012 |  | 11-001 |  |  |  | APP | 08-016 | 08-010 | 3421 | 10-030 |  |  |  |  |  |  |  |
| 13421065a |  | P-1 Vend Fab H Steel (EXIST ARC Dipoles) Labor FY11 |  | 321.8d | 2010-03-15 A | 2011-06-27 A | 13421060M | 100% |  |  | MECH ENG [18.06 h]; MECH DES [18.06 h] | 2,042.21 | 2,042.21 |  |  | 0 | 2070.2178 | BEVINS M | 1 | 1 | D | MIKE B | 08-029 |  | 10-065 |  | 09-012 |  | 11-001 |  |  |  | APP | 08-016 | 08-010 | 3421 | 10-030 |  |  |  |  |  |  |  |
| 13421065b |  | P-1 Vend Fab H Steel (EXIST ARC Dipoles) Procurement |  | 238d | 2010-03-15 A | 2011-02-28 A | 13421060M | 100% |  |  | PROCUREMENT>$50K 69 NO ESCALATION FY11; PROCUREMENT<$50K 60 NO ESCALATION FY11 | 380,788.36 |  |  |  | 0 | 380788.36 | BEVINS M | 1 | 1 | D | MIKE B | 08-029 |  | 10-065 |  | 09-012 |  | 11-001 |  |  |  | APP | 08-016 | 08-010 | 3421 | 10-030 | 0 | 380788.36 | 38078836 | 100 |  |  |  |
| 13421046a |  | Fabrication of Existing Arc Dipole Rebuild Parts (Labor) FY10 |  | 125d | 2010-08-23 A | 2011-02-28 A | 13421046 FS-60d | 100% |  |  | MECH ENG [45.78 h]; MECH DES [14.62 h]; MECH TECH [45.78 h] | 5,725.08 | 5,725.08 |  |  | 0 | 5586.879 | BEVINS M | 1 | 1 | H | MIKE B | 08-029 |  |  |  |  |  | 11-001 |  | 09-034 | 07-024 | APP | 08-016 |  |  |  |  |  |  |  |  |  |  |
| 13421046ab |  | Fabrication of Existing Arc Dipole Rebuild Parts (Labor) FY11 |  | 124.1d | 2010-08-23 A | 2011-02-28 A | 13421046 FS-60d | 100% |  |  | MECH ENG [26.22 h]; MECH DES [8.38 h]; MECH TECH [26.22 h] | 3,279.12 | 3,282.18 |  |  | 0 | 3301.217046 | BEVINS M | 1 | 1 | H | MIKE B | 08-029 |  |  |  |  |  | 11-001 |  | 09-034 | 07-024 | APP | 08-016 |  |  |  |  |  |  |  |  |  |  |
| 13421046b |  | Fabrication of Existing Arc Dipole Rebuild Parts (proc) |  | 125d | 2010-08-23 A | 2011-02-28 A | 13421046 FS-60d | 100% |  |  | PROCUREMENT<$50K 60 NO ESCALATION FY11; PROCUREMENT>$50K 69 NO ESCALATION FY11 | 374,815.8 |  |  |  | 0 | 374815.79872 | BEVINS M | 1 | 1 | D | MIKE B | 08-029 |  |  |  |  |  |  |  | 09-034 | 07-024 | APP | 08-016 |  |  |  | 0 | 374815.79872 | 37481579.872 | 100 |  |  |  |
| 13421095 |  | Vend Fab Survey Instrument |  | 31d | 2010-09-13 A | 2010-10-25 A | 9-110M | 100% |  |  | PROCUREMENT<$50K 60; PROCUREMENT>$50K 69; MECH ENG [40 h] | 183,262.56 | 2,680.06 |  |  | 0 | 183300.5 | BEVINS M | 1 | 1 | D | MIKE B |  |  | 10-065 |  |  |  |  |  |  |  |  |  |  |  |  | 0 | 180582.5 | 18058250 | 100 |  |  |  |
| 13421066 |  | P-2 Vend Fab H Steel (EXIST ARC Dipoles) |  | 172d | 2010-10-01 A | 2011-06-14 A | 13421065 FS-95d, 13421065a FS-95d, 13421065b FS-95d | 100% |  |  | PROCUREMENT<$50K 60; PROCUREMENT>$50K 69; MECH ENG [20 h]; MECH DES [20 h] | 734,083.3 | 2,292.6 |  |  | 0 | 734083.3 | BEVINS M | 1 | 1 | D | MIKE B | 08-029 |  | 10-065 |  |  |  |  |  |  |  | APP | 08-016 | 08-010 | 3421 | 10-030 | 0 | 731790.7 | 73179070 | 100 |  |  |  |
| 13421911LOE |  | FY11 Mngmnt & Oversight (EXIST ARC Dipoles) |  | 248d | 2010-10-01 A | 2011-09-30 A | 13421910LOE | 100% |  |  | SR STAFF [280 h]; TRAVEL | 54,065.19 | 30,662.8 | 100 | 100 | 0 | 54065.19 | BEVINS M | 1 | 1 | E | MIKE B | 08-029 |  |  |  |  |  |  |  |  |  |  |  |  |  |  |  |  |  |  | 8.46774193 | 91.53225806 |  |
| 13421085 |  | Vendor Fab and Delivery of Magnet Refurbishment Crane |  | 91d | 2010-10-11 A | 2011-02-28 A | 9-100M FS+234d | 100% |  |  | PROCUREMENT<$50K 60 NO ESCALATION FY11; PROCUREMENT>$50K 69 NO ESCALATION FY11 | 80,000 |  |  |  | 0 | 80000 | BEVINS M | 1 | 1 | P | MIKE B |  |  | 10-065 |  |  |  |  |  |  |  |  |  |  |  |  | 0 | 80000 | 8000000 | 100 |  |  |  |
| 13421090 |  | Installation of Magnetic Refurbishment Crane |  | 91d | 2010-10-11 A | 2011-02-28 A | 13421085 FS-50d | 100% |  |  | PROCUREMENT>$50K 69; MECH TECH [120 h]; PROCUREMENT<$50K 60 | 56,763.4 | 5,168.4 |  |  | 0 | 56763.4 | BEVINS M | 1 | 1 | D | MIKE B |  |  | 10-065 |  |  |  |  |  |  |  |  |  |  |  |  | 0 | 51595 | 5159500 | 100 |  |  |  |
| 13421067M |  | Delivery of First Article H Steel | milestone | 0d | 2010-11-15 A | 2010-11-15 A | 13421060M FS+229d | 100% | 2010-12-16 | 2010-12-16 |  |  |  |  |  |  | 0 | BEVINS M | 1 | 1 | M | MIKE B | 08-029 |  | 10-065 |  |  |  |  | 6 |  |  |  |  |  |  |  |  |  |  |  |  |  |  |
| 13421070M |  | Delivery Complete for H Steel for S/R Dipoles (EXIST ARC DIPOLES) | milestone | 0d | 2011-06-14 A | 2011-06-14 A | 13421065a, 13421065b, 13421066, 13421067M, 13421065 | 100% | 2011-07-14 | 2011-07-14 |  |  |  |  |  |  | 0 | BEVINS M | 1 | 1 | M | MIKE B | 08-029 |  | 10-065 |  |  |  |  | 6 |  |  |  |  |  |  |  |  |  |  |  |  |  |  |
| 13421912LOE |  | FY12 Mngmnt & Oversight (EXIST ARC Dipoles) |  | 151d | 2011-10-03 A | 2012-05-14 A | 13421911LOE | 100% |  |  | TRAVEL; SR STAFF [320 h] | 61,280.03 | 36,160 | 100 | 100 | 0 | 61280.03 | BEVINS M | 1 | 1 | E | MIKE B | 08-029 |  |  |  |  |  |  |  |  |  |  |  |  |  |  |  |  |  |  | 34.00809716 | 65.99190283 |  |
| 13421950 |  | Re-Baseline Actuals Adjustment |  | 1d | 2013-08-30 A | 2013-08-30 A |  | 100% | 2013-09-03 | 2013-09-03 | PROCUREMENT>$50K 69 NO ESCALATION | 189,354.88 |  |  |  |  | 189354.88 |  |  |  |  |  |  |  |  |  |  |  |  |  |  |  |  |  |  |  |  | 0 | 189354.88 | 18935488 | 100 |  |  | ADJ |

Notes:
- 13421030: Explanation: 30July2009, Scope has changed, Progressed to 100%. Changed EVMS code to / H. / 04Dec2009, Due to scope change referenced on note 30july2009, the progress / taken was for the labor portion only. The procurement ($52,398.73) was to be / used for procurement in change request 10-003. The procurement dollars have been / removed from this activity and incorporated into change request 10-003. / PMC.
- 13421030a: Explanation: 30July2009, Scope has changed, Progressed to 100%. Changed EVMS code to / H. / 04Dec2009, Due to scope change referenced on note 30july2009, the progress / taken was for the labor portion only. The procurement ($52,398.73) was to be / used for procurement in change request 10-003. The procurement dollars have been / removed from this activity and incorporated into change request 10-003. / PMC.

| ID | WBS | Activity | Type | Duration | Start | Finish | Predecessors | Complete | Planned start | Planned finish | Resources | Cost | Actual cost | Calculated Remaining Total Cost | MONTHLY EV COST | RESP - Responsibility | STRT%COMP for CM EVM | FNSH%COMP for CM EVM | EVMS Reporting Codes | CAM RESPONSIBLE | CR 08-029 | CR 08-058 | CR 10-001 | Milestone Level | CR 09-040 | Advance Purchase Plan > 500K | CR 08-016 | CR 08-044 | CR 08-051 | 12 GEV MAJOR PROCUREMENT CATAGORY | CR 09-012 | CR 10-065 | CR 12-035 | Remaining Material Cost Based on % Compl | Claimed Material Cost Based on % Complet | Initial Claimed Material Calc | Claimed Material Divider | LOE Divider | LOE Multiplier | CR 11-001 | Activities with Steps | CR 10-030 | CR 11-057 | CR 12-018 | CR 12-029 | OPC Allison | CR 12-001 | ReBaseline Actuals Adjustment |
| --- | --- | --- | --- | --- | --- | --- | --- | --- | --- | --- | --- | --- | --- | --- | --- | --- | --- | --- | --- | --- | --- | --- | --- | --- | --- | --- | --- | --- | --- | --- | --- | --- | --- | --- | --- | --- | --- | --- | --- | --- | --- | --- | --- | --- | --- | --- | --- | --- |
|  | 2 | **1.3.4.2.2 QUADRUPOLES** |  |  | 2009-01-05 | 2013-08-30 |  |  |  |  |  |  |  |  |  |  |  |  |  |  |  |  |  |  |  |  |  |  |  |  |  |  |  |  |  |  |  |  |  |  |  |  |  |  |  |  |  |  |
| 13422035 |  | Prcrmnt Prep for Quads (EXIST ARC Q-POLES) |  | 98d | 2009-01-05 A | 2009-05-25 A | 13422035XD | 100% | 2009-01-05 | 2009-05-22 | MECH DES [28.13 h]; MECH ENG [42.2 h] | 3,926 | 3,926 | 0 | 3926.0012 | BEVINS M | 1 | 1 | H | MIKE B | 08-029 | 08-058 |  |  |  |  |  |  |  |  |  |  |  |  |  |  |  |  |  |  |  |  |  |  |  |  |  |  |
| 13432004 |  | Procurement Prep for Linac Correctors FY09 |  | 109d | 2009-07-16 A | 2009-12-21 A | 9-090M FS+185d | 100% | 2009-07-16 | 2009-12-18 | MECH ENG [21.72 h]; MECH DES [21.72 h] | 2,375.86 | 2,375.86 | 0 | 2338.158 | BEVINS M | 1 | 1 | H | MIKE B | 08-029 |  | 10-001B |  |  |  |  |  |  |  |  |  |  |  |  |  |  |  |  |  |  |  |  |  |  |  |  |  |
| 13422040M |  | Award Contract for Quadrupoles (EXIST ARC Q-POLES) | milestone | 0d | 2009-08-03 A | 2009-08-03 A | 13422035, 13422035XD, 1114010, 9-090M FS+206d | 100% | 2009-09-01 | 2009-09-01 |  |  |  |  | 0 | BEVINS M | 1 | 1 | M | MIKE B | 08-029 |  |  | 6 | 09-040 |  |  |  |  |  |  |  |  |  |  |  |  |  |  |  |  |  |  |  |  |  |  |  |
| 13422045 |  | Vend Fab Quads (EXIST ARC Q-POLES) LABOR Initial |  | 37d | 2009-08-03 A | 2009-09-23 A | 9-090M FS+91d | 100% |  |  | MECH DES [55.65 h]; MECH ENG [46.37 h] | 5,398.62 | 5,398.62 | 0 | 5398.620158 | BEVINS M | 1 | 1 | H | MIKE B | 08-029 |  |  |  | 09-040 | APP | 08-016 | 08-044 | 08-051 | 3422 | 09-012 | 10-065 | 12-035F |  |  |  |  |  |  |  |  |  |  |  |  |  |  |  |
| 13422047 |  | Vend Fab Quads (EXIST ARC Q-POLES) Recieve Materials |  | 64d | 2009-08-03 A | 2009-10-30 A | 9-090M FS+206d | 100% |  |  | PROCUREMENT>$50K 69 NO ESCALATION; PROCUREMENT<$50K 60 NO ESCALATION | 84,150 |  | 0 | 84150 | BEVINS M | 1 | 1 | P | MIKE B | 08-029 |  | 10-001A |  | 09-040 | APP | 08-016 |  |  | 3422 |  | 10-065 | 12-035F | 0 | 84150 | 8415000 | 100 |  |  |  |  |  |  |  |  |  |  |  |
| 13422047A |  | Vend Fab Quads (EXIST ARC Q-POLES) Lamination Stampings |  | 97d | 2009-08-03 A | 2009-12-21 A | 13422047 FS-24d | 100% | 2009-08-03 | 2009-12-18 | PROCUREMENT>$50K 69 | 19,125 |  | 0 | 19125 | BEVINS M | 1 | 1 | P | MIKE B | 08-029 |  |  |  | 09-040 | APP | 08-016 |  |  | 3422 |  | 10-065 | 12-035F | 0 | 19125 | 1912500 | 100 |  |  |  |  |  |  |  |  |  |  |  |
| 13422047B |  | Vend Fab Quads (EXIST ARC Q-POLES) First Article QR |  | 77d | 2009-08-03 A | 2009-11-18 A | 13422047A FS-32d | 100% |  |  | PROCUREMENT>$50K 69 NO ESCALATION | 19,900 |  | 0 | 19900 | BEVINS M | 1 | 1 | P | MIKE B | 08-029 |  | 10-001A |  | 09-040 | APP | 08-016 |  |  | 3422 |  | 10-065 | 12-035F | 0 | 19900 | 1990000 | 100 |  |  |  |  |  |  |  |  |  |  |  |
| 13422047C |  | Vend Fab Quads (EXIST ARC Q-POLES) Deliver 5 QR Magnets |  | 116d | 2009-08-03 A | 2010-01-25 A | 13422047B FS-41d | 100% |  |  | PROCUREMENT>$50K 69 NO ESCALATION | 38,500 |  | 0 | 38500 | BEVINS M | 1 | 1 | P | MIKE B | 08-029 |  | 10-001A |  | 09-040 | APP | 08-016 |  |  | 3422 |  | 10-065 | 12-035F | 0 | 38500 | 3850000 | 100 |  |  |  |  |  |  |  |  |  |  |  |
| 13422047D |  | Vend Fab Quads (EXIST ARC Q-POLES) Deliver 5 QR Magnets |  | 138d | 2009-08-03 A | 2010-02-25 A | 13422047C FS-99d | 100% |  |  | PROCUREMENT>$50K 69 NO ESCALATION | 38,500 |  | 0 | 38500 | BEVINS M | 1 | 1 | P | MIKE B | 08-029 |  | 10-001A |  | 09-040 | APP | 08-016 |  |  | 3422 |  | 10-065 | 12-035F | 0 | 38500 | 3850000 | 100 |  |  |  |  |  |  |  |  |  |  |  |
| 13422047F |  | Vend Fab Quads (EXIST ARC Q-POLES) Deliver 5 QR Magnets |  | 160d | 2009-08-03 A | 2010-03-29 A | 13422047D FS-118d | 100% |  |  | PROCUREMENT>$50K 69 NO ESCALATION | 38,500 |  | 0 | 38500 | BEVINS M | 1 | 1 | D | MIKE B | 08-029 |  | 10-001A |  | 09-040 | APP | 08-016 |  |  | 3422 |  | 10-065 | 12-035F | 0 | 38500 | 3850000 | 100 |  |  |  |  |  |  |  |  |  |  |  |
| 13422047G |  | Vend Fab Quads (EXIST ARC Q-POLES) Deliver 5 QR Magnets |  | 160d | 2009-08-03 A | 2010-03-29 A | 13422047F FS-139d | 100% |  |  | PROCUREMENT>$50K 69 NO ESCALATION | 38,500 |  | 0 | 38500 | BEVINS M | 1 | 1 | D | MIKE B | 08-029 |  | 10-001A |  | 09-040 | APP | 08-016 |  |  | 3422 |  | 10-065 | 12-035F | 0 | 38500 | 3850000 | 100 |  |  |  |  |  |  |  |  |  |  |  |
| 13422047H |  | Vend Fab Quads (EXIST ARC Q-POLES) Deliver 5 QR Magnets |  | 178d | 2009-08-03 A | 2010-04-22 A | 13422047G FS-163d | 100% |  |  | PROCUREMENT>$50K 69 NO ESCALATION | 38,500 |  | 0 | 38500 | BEVINS M | 1 | 1 | D | MIKE B | 08-029 |  | 10-001A |  | 09-040 | APP | 08-016 |  |  | 3422 |  | 10-065 | 12-035F | 0 | 38500 | 3850000 | 100 |  |  |  |  |  |  |  |  |  |  |  |
| 13422047J |  | Vend Fab Quads (EXIST ARC Q-POLES) Deliver 5 QR Magnets |  | 178d | 2009-08-03 A | 2010-04-22 A | 13422047H FS-183d | 100% |  |  | PROCUREMENT>$50K 69 NO ESCALATION | 38,500 |  | 0 | 38500 | BEVINS M | 1 | 1 | D | MIKE B | 08-029 |  | 10-001A |  | 09-040 | APP | 08-016 |  |  | 3422 |  | 10-065 | 12-035F | 0 | 38500 | 3850000 | 100 |  |  |  |  |  |  |  |  |  |  |  |
| 13422047K |  | Vend Fab Quads (EXIST ARC Q-POLES) Deliver 4 QR Magnets |  | 243d | 2009-08-03 A | 2010-07-26 A | 13422047J FS-200d | 100% |  |  | PROCUREMENT>$50K 69 NO ESCALATION | 30,800 |  | 0 | 30800 | BEVINS M | 1 | 1 | D | MIKE B | 08-029 |  | 10-001A |  | 09-040 | APP | 08-016 |  |  | 3422 |  | 10-065 | 12-035F | 0 | 30800 | 3080000 | 100 |  |  |  |  |  |  |  |  |  |  |  |
| 13422047L |  | Vend Fab Quads (EXIST ARC Q-POLES) Deliver 2 QR Magnets |  | 243d | 2009-08-03 A | 2010-07-26 A | 13422047K FS-222d | 100% |  |  | PROCUREMENT>$50K 69 NO ESCALATION; PROCUREMENT<$50K 60 NO ESCALATION | 20,600 |  | 0 | 20600 | BEVINS M | 1 | 1 | D | MIKE B | 08-029 |  | 10-001A |  | 09-040 | APP | 08-016 |  |  | 3422 |  | 10-065 | 12-035F | 0 | 20600 | 2060000 | 100 |  |  |  |  |  |  |  |  |  |  |  |
| 13422046 |  | Vend Fab Quads (EXIST ARC Q-POLES) LABOR Final FY09 |  | 26.23d | 2009-09-24 A | 2009-10-30 A | 13422045 FS-120d | 100% |  |  | MECH ENG [22.25 h]; MECH DES [17.8 h] | 2,257.03 | 2,257.03 | 0 | 2200.1245 | BEVINS M | 1 | 1 | E | MIKE B | 08-029 |  | 10-001B |  | 09-040 | APP | 08-016 |  |  | 3422 | 09-012 | 10-065 | 12-035F |  |  |  |  | 100 | 100 |  |  |  |  |  |  |  |  |  |
| 13432004b |  | Procurement Prep for Linac Correctors FY10 |  | 56d | 2009-09-30 A | 2009-12-21 A | 13432004 FS-300d | 100% | 2009-09-30 | 2009-12-18 | MECH ENG [18.28 h]; MECH DES [18.28 h] | 2,029.6 | 2,029.6 | 0 | 2030.7252 | BEVINS M | 1 | 1 | H | MIKE B |  |  | 10-001B |  |  |  |  |  |  |  |  |  |  |  |  |  |  |  |  |  |  |  |  |  |  |  |  |  |
| 13422046b |  | Vend Fab Quads (EXIST ARC Q-POLES) LABOR Final FY10 |  | 265.86d | 2009-10-01 A | 2010-10-26 A | 13422046 | 100% |  |  | MECH DES [105.07 h]; MECH ENG [131.37 h] | 13,432.78 | 13,432.78 | 0 | 13404.0813 | BEVINS M | 1 | 1 | E | MIKE B |  |  | 10-001B |  |  | APP |  |  |  | 3422 |  | 10-065 | 12-035F |  |  |  |  | 100 | 100 | 11-001 |  |  |  |  |  |  |  |  |
| 13422046ba |  | Vend Fab Quads (EXIST ARC Q-POLES) LABOR Final FY11 |  | 266d | 2009-10-01 A | 2010-10-26 A | 13422046 | 100% |  |  | MECH ENG [9.53 h]; MECH DES [7.63 h] | 974.82 | 974.82 | 0 | 1003.7319 | BEVINS M | 1 | 1 | E | MIKE B |  |  | 10-001B |  |  | APP |  |  |  | 3422 |  | 10-065 | 12-035F |  |  |  |  | 100 | 100 | 11-001 |  |  |  |  |  |  |  |  |
| 13422055 |  | Mag Measurment of New Quads (EXIST ARC Q-POLES) FY10 |  | 161d | 2009-11-30 A | 2010-07-26 A | 13422050M FS-600d | 100% |  |  | MECH TECH [108.16 h]; MECH ENG [64.48 h] | 8,760.61 | 8,760.61 | 0 | 8760.6064 | BEVINS M | 1 | 1 | H | MIKE B | 08-029 |  |  |  | 09-040 |  |  |  |  |  |  | 10-065 | 12-035F |  |  |  |  |  |  | 11-001 |  |  |  |  |  |  |  |  |
| 13422055a |  | Mag Measurment of New Quads (EXIST ARC Q-POLES) FY11 |  | 161d | 2009-11-30 A | 2010-07-26 A | 13422050M FS-600d | 100% |  |  | MECH TECH [99.84 h]; MECH ENG [59.52 h] | 8,086.71 | 8,086.71 | 0 | 8344.4928 | BEVINS M | 1 | 1 | H | MIKE B | 08-029 |  |  |  | 09-040 |  |  |  |  |  |  | 10-065 | 12-035F |  |  |  |  |  |  | 11-001 |  |  |  |  |  |  |  |  |
| 13422050M |  | Delivery Complete forQuadrupoles (EXIST ARC Q-POLES) | milestone | 0d | 2010-07-26 A | 2010-07-26 A | 13422047L, 13422046b, 13422046ba | 100% | 2010-11-24 | 2010-11-24 |  |  |  |  | 0 | BEVINS M | 1 | 1 | M | MIKE B | 08-029 |  |  | 6 | 09-040 |  |  |  |  |  |  | 10-065 | 12-035F |  |  |  |  |  |  |  |  |  |  |  |  |  |  |  |
| 13422065 |  | Measure 69 S/R Quads at Higher Current (EXIST ARC Q-POLES) |  | 17d | 2011-04-01 A | 2011-04-25 A | 9-120M | 100% |  |  |  |  |  |  | 0 | BEVINS M | 1 | 1 | U | MIKE B | 08-029 |  |  |  |  |  |  |  |  |  |  | 10-065 |  |  |  |  |  |  |  |  |  |  |  |  |  |  |  |  |
| 13422100 |  | Prcrmnt Prep for QY Quads FY10 |  | 11d | 2011-05-02 A | 2011-05-16 A | 9-100M FS+120d | 100% |  |  | MECH ENG [273.4 h]; MECH DES [211.25 h] | 28,438.68 | 28,438.68 | 0 | 27560.34 | BEVINS M | 1 | 1 | S | MIKE B |  |  |  |  |  |  |  |  |  |  |  | 10-065 | 12-035F |  |  |  |  |  |  |  | ST | 10-030 | 11-057 | 12-018F | 12-029F |  |  |  |
| 13422102 |  | Prcrmnt Prep for QY Quads FY10b |  | 11d | 2011-05-09 A | 2011-05-23 A | 13422100 | 100% |  |  | MECH ENG [497.72 h]; MECH DES [384.62 h] | 51,774.13 | 51,774.13 | 0 | 50175.0708 | BEVINS M | 1 | 1 | S | MIKE B |  |  |  |  |  |  |  |  |  |  |  | 10-065 | 12-035F |  |  |  |  |  |  | 11-001 | ST | 10-030 | 11-057 | 12-018F | 12-029F |  |  |  |
| 13422110 |  | Vend Fab QY Quads Labor Support FY11 |  | 11d | 2011-05-09 A | 2011-05-23 A | 13422105M | 100% |  |  | MECH DES [80 h]; MECH ENG [320 h] | 25,478.4 | 25,478.4 | 0 | 25478.4 | BEVINS M | 1 | 1 | H | MIKE B |  |  |  |  |  | APP |  |  |  | 3422 |  | 10-065 | 12-035F |  |  |  |  |  |  |  |  | 10-030 | 11-057 | 12-018F | 12-029F |  |  |  |
| 13422115 |  | Vend Fab QY Quads 1st Article |  | 10d | 2011-05-16 A | 2011-05-30 A | 13422105M | 100% | 2011-05-16 | 2011-05-27 | PROCUREMENT<$50K 60 | 41,276 |  | 0 | 41276 | BEVINS M | 1 | 1 | P | MIKE B |  |  |  |  |  | APP |  |  |  | 3422 |  | 10-065 | 12-035F | 0 | 41276 | 4127600 | 100 |  |  |  |  | 10-030 | 11-057 | 12-018F | 12-029F |  |  |  |
| 13422123 |  | Magnetic Measurement QY Quads |  | 11d | 2011-08-01 A | 2011-08-15 A | 9-110M FS+98d, 13422122 FS-500d, 13422125M FS-500d | 100% |  |  | MECH ENG [23.04 h]; MECH TECH [115.22 h] | 6,528.1 | 6,528.1 | 0 | 6528.0934 | BEVINS M | 1 | 1 | U | MIKE B |  |  |  |  |  | APP |  |  |  | 3422 |  | 10-065 | 12-035F |  |  |  |  |  |  |  |  | 10-030 | 11-057 | 12-018F | 12-029F |  |  |  |
| 13422105M |  | Award Contract for QY Quadrupoles | milestone | 0d | 2011-08-31 A | 2011-08-31 A | 13422102a, 13422102 | 100% | 2012-01-25 | 2012-01-25 |  |  |  |  | 0 | BEVINS M | 1 | 1 | M | MIKE B |  |  |  | 6 |  |  |  |  |  |  |  | 10-065 | 12-035F |  |  |  |  |  |  |  |  | 10-030 | 11-057 | 12-018F | 12-029F |  |  |  |
| 13422122 |  | Receive and Inspect QY Quads |  | 17d | 2011-09-05 A | 2011-09-28 A | 13422115 FS-43d | 100% | 2011-09-06 | 2011-09-28 | MECH TECH [74.34 h]; MECH ENG [74.34 h]; MECH DES [24.78 h]; COMP SCIENT [24.78 h] | 10,985.71 | 10,985.71 | 0 | 10985.7174 | BEVINS M | 1 | 1 | U | MIKE B |  |  |  |  |  | APP |  |  |  | 3422 |  | 10-065 | 12-035F |  |  |  |  |  |  |  |  | 10-030 | 11-057 | 12-018F | 12-029F |  |  |  |
| 13422112 |  | Vend Fab QY Quads Labor Support FY12 |  | 12d | 2011-09-12 A | 2011-09-27 A | 13422110 | 100% |  |  | MECH DES [20.51 h]; MECH ENG [82.05 h] | 6,532.71 | 6,532.71 | 0 | 6532.7043 | BEVINS M | 1 | 1 | H | MIKE B |  |  |  |  |  | APP |  |  |  | 3422 |  | 10-065 | 12-035F |  |  |  |  |  |  |  |  | 10-030 | 11-057 | 12-018F | 12-029F |  |  |  |
| 13422102a |  | Prcrmnt Prep for QY Quads FY11 |  | 8d | 2011-09-14 A | 2011-09-24 A | 13422102, 13422100, 9-120M FS+30d | 100% | 2011-09-14 | 2011-09-23 | MECH ENG [108.88 h]; MECH DES [84.13 h] | 11,325.59 | 11,325.59 | 0 | 11325.5844 | BEVINS M | 1 | 1 | S | MIKE B |  |  |  |  |  |  |  |  |  |  |  | 10-065 | 12-035F |  |  |  |  |  |  | 11-001 | ST | 10-030 | 11-057 | 12-018F | 12-029F |  |  |  |
| 13422060 |  | Add Klixons to 20 Amp Quads (EXIST ARC Q-POLES) |  | 253d | 2012-04-09 A | 2013-06-17 A | 2-02M FS-30d, 13422055, 13422055a | 100% | 2012-04-09 | 2013-04-15 | PROCUREMENT<$50K 60; PROCUREMENT>$50K 69; MECH TECH [132 h] | 32,483.58 | 5,976.52 | 0 | 32386.53 | BEVINS M | 1 | 1 | U | MIKE B | 08-029 |  |  |  |  | APP |  | 08-044 |  |  |  | 10-065 | 12-035 | 0 | 26520.45 | 2652045 | 100 |  |  |  |  |  |  |  |  |  |  |  |
| 13422120 |  | Vend Fab Additional QR Quads |  | 48d | 2013-03-04 A | 2013-04-15 A | 9-130M, 13422115 FS-106d | 100% | 2013-05-03 | 2013-07-11 | PROCUREMENT<$50K 60; PROCUREMENT>$50K 69 | 62,243.18 |  | 0 | 62243.18 | BEVINS M | 1 | 1 | D | MIKE B |  |  |  |  |  | APP |  |  |  | 3422 |  | 10-065 | 12-035F | 0 | 62243.18 | 6224318 | 100 |  |  |  |  | 10-030 | 11-057 | 12-018F | 12-029F | OPC A |  |  |
| 13422123a |  | Magnetic Measurement QR Quads FY11 |  | 14d | 2013-03-04 A | 2013-03-18 A | 13422120 FS-500d, 13422125M FS-500d, 13422122 FS-184d | 100% | 2013-06-27 | 2013-07-17 | MECH ENG [1.47 h]; MECH TECH [7.37 h] | 444.36 | 444.36 | 0 | 417.3124 | BEVINS M | 1 | 1 | U | MIKE B |  |  |  |  |  | APP |  |  |  | 3422 |  | 10-065 | 12-035F |  |  |  |  |  |  |  |  | 10-030 | 11-057 | 12-018F | 12-029F | OPC A | 12-001 |  |
| 13422123b |  | Magnetic Measurement QR Quads FY12 |  | 5d | 2013-03-04 A | 2013-04-15 A | 13422123a | 100% | 2013-07-18 | 2013-07-24 | MECH ENG [15.49 h]; MECH TECH [77.41 h] | 4,670.88 | 4,670.88 | 0 | 4526.2592 | BEVINS M | 1 | 1 | U | MIKE B |  |  |  |  |  | APP |  |  |  | 3422 |  | 10-065 | 12-035F |  |  |  |  |  |  |  |  | 10-030 | 11-057 | 12-018F | 12-029F | OPC A | 12-001 |  |
| 13422122a |  | Receive and Inspect QR Quads |  | 14d | 2013-03-11 A | 2013-04-15 A | 13422120 FS-400d | 100% | 2013-06-27 | 2013-07-17 | MECH TECH [45.66 h]; MECH ENG [45.66 h]; MECH DES [15.22 h]; COMP SCIENT [15.22 h] | 7,185.07 | 7,185.07 | 0 | 6962.6934 | BEVINS M | 1 | 1 | U | MIKE B |  |  |  |  |  | APP |  |  |  | 3422 |  | 10-065 | 12-035F |  |  |  |  |  |  |  |  | 10-030 | 11-057 | 12-018F | 12-029F | OPC A |  |  |
| 13422117 |  | Vend Fab QR Quads Labor Support |  | 48d | 2013-04-04 A | 2013-04-22 A | 9-130M FS+165d | 100% | 2013-06-04 | 2013-08-09 | MECH DES [59.49 h]; MECH ENG [237.95 h] | 20,175.31 |  | 0 | 19550.6873 | BEVINS M | 1 | 1 | P | MIKE B |  |  |  |  |  | APP |  |  |  | 3422 |  | 10-065 | 12-035F |  |  |  |  |  |  |  |  | 10-030 | 11-057 | 12-018F | 12-029F | OPC A |  |  |
| 13422125M |  | Delivery Complete for QR Quadrupoles | milestone | 0d | 2013-04-15 A | 2013-04-15 A | 13422112, 13422122, 13422115, 13422120, 13422122a FS-20d | 100% | 2014-06-04 | 2014-06-04 |  |  |  |  | 0 | BEVINS M | 1 | 1 | M | MIKE B |  |  |  | 6 |  |  |  |  |  |  |  | 10-065 | 12-035F |  |  |  |  |  |  |  |  | 10-030 | 11-057 | 12-018F | 12-029F | OPC A |  |  |
| 13422130 |  | Re-Baseline Actuals Adjustment |  | 1d | 2013-08-30 A | 2013-08-30 A |  | 100% | 2013-09-03 | 2013-09-03 | PROCUREMENT>$50K 69 NO ESCALATION | -78,852.33 |  |  |  |  |  |  |  |  |  |  |  |  |  |  |  |  |  |  |  |  |  |  |  |  | 100 |  |  |  |  |  |  |  |  |  |  | ADJ |

Notes:
- 13422100: Steps: Design Phase 1 (specifications and preliminary modeling) (done); Design Phase 2 (finalize design and acceptance) (done); Design Phase 3 (final drawings and documentation) (done)
- 13422102: Steps: Prcmnt Prep P1 (SOW and procurement documentation) (done); Prcmnt Prep P2 (Initial solicitation evaluation) (done); Prcmnt Prep P3 (BAFO and award) (done)
- 13422123: Steps: Mechanical Inspection QY 1st Article; Magnetic Measurement QY 1st Article; Mechanical Inspection QY2; Magnetic Measurement QY2; Mechanical Inspection QY3; Magnetic Measurement QY3; Mechanical Inspection QY4; Magnetic Measurement QY4; Mechanical Inspection QY5; Magnetic Measurement QY5
- 13422122: Steps: Mechanical Inspection QY 1st Article; Magnetic Measurement QY 1st Article; Mechanical Inspection QY2; Magnetic Measurement QY2; Mechanical Inspection QY3; Magnetic Measurement QY3; Mechanical Inspection QY4; Magnetic Measurement QY4; Mechanical Inspection QY5; Magnetic Measurement QY5
- 13422102a: Steps: Prcmnt Prep P1 (SOW and procurement documentation) (done); Prcmnt Prep P2 (Initial solicitation evaluation) (done); Prcmnt Prep P3 (BAFO and award) (done)
- 13422123a: Steps: Mechanical Inspection QY 1st Article; Magnetic Measurement QY 1st Article; Mechanical Inspection QY2; Magnetic Measurement QY2; Mechanical Inspection QY3; Magnetic Measurement QY3; Mechanical Inspection QY4; Magnetic Measurement QY4; Mechanical Inspection QY5; Magnetic Measurement QY5
- 13422123b: Steps: Mechanical Inspection QY 1st Article; Magnetic Measurement QY 1st Article; Mechanical Inspection QY2; Magnetic Measurement QY2; Mechanical Inspection QY3; Magnetic Measurement QY3; Mechanical Inspection QY4; Magnetic Measurement QY4; Mechanical Inspection QY5; Magnetic Measurement QY5
- 13422122a: Steps: Mechanical Inspection QY 1st Article; Magnetic Measurement QY 1st Article; Mechanical Inspection QY2; Magnetic Measurement QY2; Mechanical Inspection QY3; Magnetic Measurement QY3; Mechanical Inspection QY4; Magnetic Measurement QY4; Mechanical Inspection QY5; Magnetic Measurement QY5

| ID | WBS | Activity | Type | Duration | Start | Finish | Predecessors | Complete | Planned start | Planned finish | Calendar | Resources | Cost | Actual cost | Calculated Remaining Total Cost | MONTHLY EV COST | RESP - Responsibility | STRT%COMP for CM EVM | FNSH%COMP for CM EVM | EVMS Reporting Codes | CAM RESPONSIBLE | CR 09-034 | CR 11-057 | CR 08-016 | CR 09-012 | CR 10-030 | Remaining Material Cost Based on % Compl | Claimed Material Cost Based on % Complet | Initial Claimed Material Calc | Claimed Material Divider | ReBaseline Actuals Adjustment | LOE % Pre Calc | LOE % | LOE Divider | LOE Multiplier | Proj SYS CODE | DOWN PERIOD | 12GEV INSTALLATION SCOPE | CR 10-065 | CR 11-001 | 12GEV PROJ ACT ID | LOCATION NAME | CR 07-024 | CR 11-052 | CR 12-035 | CR 12-053 | Installation | CR 10-028 | CR 08-044 | OPC Allison | CR 12-028 | MARCH!!! | CR 13-003 | Specification | CR 12-018 | CR 12-029 | CR 08-029 | Activities with Steps | Original Activity ID Rebaseline | PRIOR MONTH EV COST | BOE Labor | CR 13-015 | Post Rebaseline |
| --- | --- | --- | --- | --- | --- | --- | --- | --- | --- | --- | --- | --- | --- | --- | --- | --- | --- | --- | --- | --- | --- | --- | --- | --- | --- | --- | --- | --- | --- | --- | --- | --- | --- | --- | --- | --- | --- | --- | --- | --- | --- | --- | --- | --- | --- | --- | --- | --- | --- | --- | --- | --- | --- | --- | --- | --- | --- | --- | --- | --- | --- | --- | --- |
|  | 3 | **1.3.4.2.3 CORRECTORS** |  |  |  |  |  |  |  |  |  |  |  |  |  |  |  |  |  |  |  |  |  |  |  |  |  |  |  |  |  |  |  |  |  |  |  |  |  |  |  |  |  |  |  |  |  |  |  |  |  |  |  |  |  |  |  |  |  |  |  |  |  |
|  | 4 | **1.3.4.2.4 STANDS** |  |  | 2010-02-01 | 2013-08-30 |  |  |  |  |  |  |  |  |  |  |  |  |  |  |  |  |  |  |  |  |  |  |  |  |  |  |  |  |  |  |  |  |  |  |  |  |  |  |  |  |  |  |  |  |  |  |  |  |  |  |  |  |  |  |  |  |  |
| 13425020 |  | Proc Girder Matrl (EXIST ARC Girders) |  | 15d | 2010-02-01 A | 2010-02-22 A | 121425010, 9-090M FS+60d | 100% |  |  |  | MECH ENG [27.2 h]; MECH DES [27.2 h] | 3,021.65 | 3,021.65 | 0 | 2928.08 | BEVINS M | 1 | 1 | H | MIKE B | 09-034 | 11-057 |  |  |  |  |  |  |  |  |  |  |  |  |  |  |  |  |  |  |  |  |  |  |  |  |  |  |  |  |  |  |  |  |  |  |  |  |  |  |  |  |
| 13425025 |  | Proc Prep of Girders/Stands for QY Quads (EXIST ARC Girders) |  | 93d | 2011-01-17 A | 2011-05-29 A | 13422100 FS-20d, 9-110M, 13425020 | 100% | 2011-01-18 | 2011-05-27 |  | MECH DES [240 h]; MECH ENG [208 h] | 25,336.8 | 25,336.8 | 0 | 25336.8 | BEVINS M | 1 | 1 | H | MIKE B | 09-034 | 11-057 | 08-016 | 09-012 | 10-030 |  |  |  |  |  |  |  |  |  |  |  |  |  |  |  |  |  |  |  |  |  |  |  |  |  |  |  |  |  |  |  |  |  |  |  |  |  |
| 13425030 |  | Vend Fab Girders/Stands for QY Quads (EXIST ARC Girders) |  | 10d | 2011-09-03 A | 2011-09-19 A | 13425025, 9-100M FS+85d, 13425020, 9-120M FS+80d | 100% | 2011-09-06 | 2011-09-19 |  | PROCUREMENT<$50K 60 | 28,790.02 |  | 0 | 28790.02 | BEVINS M | 1 | 1 | P | MIKE B | 09-034 | 11-057 | 08-016 | 09-012 | 10-030 | 0 | 28790.02 | 2879002 | 100 |  |  |  |  |  |  |  |  |  |  |  |  |  |  |  |  |  |  |  |  |  |  |  |  |  |  |  |  |  |  |  |  |  |
| 13425035 |  | Re-Baseline Actuals Adjustment |  | 1d | 2013-08-30 A | 2013-08-30 A |  | 100% | 2013-09-03 | 2013-09-03 |  | PROCUREMENT>$50K 69 NO ESCALATION | -36,112.05 |  |  |  |  |  |  |  |  |  |  |  |  |  |  |  |  | 100 | ADJ |  |  |  |  |  |  |  |  |  |  |  |  |  |  |  |  |  |  |  |  |  |  |  |  |  |  |  |  |  |  |  |  |
|  | 5 | **1.3.4.2.5 GIRDERS** |  |  |  |  |  |  |  |  |  |  |  |  |  |  |  |  |  |  |  |  |  |  |  |  |  |  |  |  |  |  |  |  |  |  |  |  |  |  |  |  |  |  |  |  |  |  |  |  |  |  |  |  |  |  |  |  |  |  |  |  |  |
|  | 6 | **1.3.4.2.6 VACUUM** |  |  | 2013-08-30 | 2013-08-30 |  |  |  |  |  |  |  |  |  |  |  |  |  |  |  |  |  |  |  |  |  |  |  |  |  |  |  |  |  |  |  |  |  |  |  |  |  |  |  |  |  |  |  |  |  |  |  |  |  |  |  |  |  |  |  |  |  |
| 13426000 |  | Re-Baseline Actuals Adjustment |  | 1d | 2013-08-30 A | 2013-08-30 A |  | 100% | 2013-09-03 | 2013-09-03 |  | PROCUREMENT>$50K 69 NO ESCALATION | 4,286.31 |  |  | 4286.31 |  |  |  |  |  |  |  |  |  |  | 0 | 4286.31 | 428631 | 100 | ADJ |  |  |  |  |  |  |  |  |  |  |  |  |  |  |  |  |  |  |  |  |  |  |  |  |  |  |  |  |  |  |  |  |
|  | 7 | **1.3.4.2.7 INSTALLATION** |  |  | 2010-07-01 | 2013-11-27 |  |  |  |  |  |  |  |  |  |  |  |  |  |  |  |  |  |  |  |  |  |  |  |  |  |  |  |  |  |  |  |  |  |  |  |  |  |  |  |  |  |  |  |  |  |  |  |  |  |  |  |  |  |  |  |  |  |
| 13427180 |  | Accelerator Down Planning FY10 |  | 210.9d | 2010-07-01 A | 2011-05-09 A | 9-100M FS+185d | 100% |  |  |  | MECH TECH [144 h]; MECH ENG [288 h] | 25,530.02 | 25,530.03 | 0 | 24975.36 | BEVINS M | 1 | 1 | E | MIKE B |  |  |  |  |  |  |  |  |  |  | 285.714285 | -185.714285 | 100 | 100 | BM TR 12GE | 6MON | W/A DIPOLES | 10-065 | 11-001 |  |  |  |  |  |  |  |  |  |  |  |  |  |  |  |  |  |  |  |  |  |  |  |
| 13427180a |  | Accelerator Down Planning FY11 |  | 211d | 2010-07-01 A | 2011-05-09 A | 9-100M FS+185d | 100% |  |  |  | MECH TECH [336 h]; MECH ENG [672 h] | 59,570.33 | 59,570.33 | 0 | 60133.92 | BEVINS M | 1 | 1 | E | MIKE B |  |  |  |  |  |  |  |  |  |  | 285.714285 | -185.714285 | 100 | 100 | BM TR 12GE | 6MON | W/A DIPOLES | 10-065 | 11-001 |  |  |  |  |  |  |  |  |  |  |  |  |  |  |  |  |  |  |  |  |  |  |  |
| 13427055 |  | Procure new material handling equipment |  | 111d | 2010-10-11 A | 2011-03-28 A | 9-110M FS+25d | 100% |  |  |  | MECH TECH [80 h]; PROCUREMENT<$50K 60 | 137,592.6 | 3,445.6 | 0 | 137592.6 | BEVINS M | 1 | 1 | D | MIKE B |  |  |  |  |  | 0 | 134147 | 13414700 | 100 |  |  |  |  |  |  |  |  | 10-065 |  |  |  |  |  |  |  |  |  |  |  |  |  |  |  |  |  |  |  |  |  |  |  |  |
| 13427060 |  | Procure Temporary Space for expanded technician work force |  | 93d | 2010-12-06 A | 2011-04-25 A | 9-110M | 100% |  |  |  | PROCUREMENT<$50K 60; PROCUREMENT>$50K 69 | 77,392.5 |  | 0 | 77392.5 | BEVINS M | 1 | 1 | D | MIKE B |  |  |  |  |  | 0 | 77392.5 | 7739250 | 100 |  |  |  |  |  |  |  |  | 10-065 |  |  |  |  |  |  |  |  |  |  |  |  |  |  |  |  |  |  |  |  |  |  |  |  |
| 13427063LOE |  | Tech Training |  | 41d | 2011-04-01 A | 2011-05-30 A | 9-110M FS+100d | 100% | 2011-04-01 | 2011-05-27 |  | MECH TECH [5280 h]; MECH ENG [160 h] | 238,281.6 | 238,281.6 | 0 | 238281.6 | BEVINS M | 1 | 1 | H | MIKE B |  |  |  |  |  |  |  |  |  |  |  |  | 100 | 100 |  |  |  | 10-065 |  |  |  |  |  |  |  |  |  |  |  |  |  |  |  |  |  |  |  |  |  |  |  |  |
| 13427065 |  | AS-FOUND SURVEY (B/L UNDER VACUUM) SOUTH SIDE WEST ARC |  | 11d | 2011-05-08 A | 2011-05-23 A | 4A-01M FS+5d | 100% | 2011-05-09 | 2011-05-23 |  | MECH TECH [220.8 h] | 9,509.86 | 9,509.86 | 0 | 9509.856 | BEVINS M | 1 | 1 | H | MIKE B |  |  |  |  |  |  |  |  |  |  |  |  |  |  | BM TR 12GE | 6MON | W/A DIPOLES | 10-065 |  |  |  |  |  |  |  |  |  |  |  |  |  |  |  |  |  |  |  |  |  |  |  |  |
| 13427120 |  | REMOVE MAGNETS - QUAD 1 |  | 5d | 2011-05-09 A | 2011-05-13 A | 13427070 | 100% |  |  |  | ELEC TECH [36.8 h]; MECH TECH [404.8 h] | 19,008.68 | 19,008.68 | 0 | 19008.672 | BEVINS M | 1 | 1 | H | MIKE B |  |  |  |  |  |  |  |  |  |  |  |  |  |  |  | 6MON |  | 10-065 |  |  |  |  |  |  |  |  |  |  |  |  |  |  |  |  |  |  |  |  |  |  |  |  |
| 13427135 |  | REMOVE MAGNETS - QUAD 2 |  | 6d | 2011-05-09 A | 2011-05-16 A | 13427120 FS-2d | 100% |  |  |  | MECH TECH [404.8 h]; ELEC TECH [36.8 h] | 19,008.68 | 19,008.68 | 0 | 19008.672 | BEVINS M | 1 | 1 | H | MIKE B |  |  |  |  |  |  |  |  |  |  |  |  |  |  |  | 6MON |  | 10-065 |  |  |  |  |  |  |  |  |  |  |  |  |  |  |  |  |  |  |  |  |  |  |  |  |
| 13427062LOE |  | Engineering Support 6 Month Down |  | 80d | 2011-05-13 A | 2011-09-06 A | 4A-01M | 100% |  |  |  | MECH ENG [1440 h] | 97,848 | 97,848 | 0 | 97848 | BEVINS M | 1 | 1 | E | MIKE B |  |  |  |  |  |  |  |  |  |  | 3.75 | 96.25 | 100 | 100 |  |  |  | 10-065 |  |  |  |  |  |  |  |  |  |  |  |  |  |  |  |  |  |  |  |  |  |  |  |  |
| 13427070 |  | BLEED UP VACUUM SOUTH SIDE OF W/ARC |  | 2d | 2011-05-20 A | 2011-05-23 A | 13427065 | 100% |  |  |  | MECH TECH [20 h] | 861.4 | 861.4 | 0 | 861.4 | BEVINS M | 1 | 1 | H | MIKE B |  |  |  |  |  |  |  |  |  |  |  |  |  |  | BM TR 12GE | 6MON | W/A DIPOLES | 10-065 |  | 13427030 | W Arc Quad 2 Stack 8 |  |  |  |  |  |  |  |  |  |  |  |  |  |  |  |  |  |  |  |  |  |
| 13427075 |  | AS-FOUND SURVEY (B/L UNDER VACUUM) NORTH SIDE WEST ARC |  | 6d | 2011-05-20 A | 2011-05-29 A | 13427065 | 100% | 2011-05-20 | 2011-05-27 |  | MECH TECH [220.8 h] | 9,509.86 | 9,509.86 | 0 | 9509.856 | BEVINS M | 1 | 1 | H | MIKE B |  |  |  |  |  |  |  |  |  |  |  |  |  |  | BM TR 12GE | 6MON | W/A DIPOLES | 10-065 |  |  |  |  |  |  |  |  |  |  |  |  |  |  |  |  |  |  |  |  |  |  |  |  |
| 13427125 |  | REFURB, UPGRADE AND TEST MAGNETS - QUAD 1 |  | 24d | 2011-05-23 A | 2011-06-25 A | 13427120 FS-20d | 100% | 2011-05-23 | 2011-06-24 |  | MECH TECH [1545.6 h]; MSHOP | 80,437.73 | 66,568.99 | 0 | 80437.732 | BEVINS M | 1 | 1 | H | MIKE B |  |  |  |  |  |  |  |  |  |  |  |  |  |  | BM TR 12GE | 6MON | W/A DIPOLES | 10-065 |  |  |  |  |  |  |  |  |  |  |  |  |  |  |  |  |  |  |  |  |  |  |  |  |
| 13427130 |  | INSTALL MAGNETS AND ARC 10 - QUAD 1 |  | 14d | 2011-05-23 A | 2011-06-11 A | 13427125 FS-15d | 100% | 2011-05-23 | 2011-06-10 |  | ELEC TECH [73.6 h]; MECH TECH [818.8 h] | 38,413.59 | 38,413.59 | 0 | 38413.588 | BEVINS M | 1 | 1 | H | MIKE B |  |  |  |  |  |  |  |  |  |  |  |  |  |  | BM TR 12GE | 6MON | W/A DIPOLES | 10-065 |  |  |  |  |  |  |  |  |  |  |  |  |  |  |  |  |  |  |  |  |  |  |  |  |
| 13427140 |  | REFURB, UPGRADE AND TEST MAGNETS - QUAD 2 |  | 15d | 2011-05-23 A | 2011-06-13 A | 13427135, 13427125 FS-20d | 100% |  |  |  | MECH TECH [1545.6 h]; MSHOP | 80,437.73 | 66,568.99 | 0 | 80437.732 | BEVINS M | 1 | 1 | H | MIKE B |  |  |  |  |  |  |  |  |  |  |  |  |  |  | BM TR 12GE | 6MON | W/A DIPOLES | 10-065 |  |  |  |  |  |  |  |  |  |  |  |  |  |  |  |  |  |  |  |  |  |  |  |  |
| 13427150 |  | REMOVE MAGNETS - QUAD 3 |  | 4d | 2011-05-25 A | 2011-05-31 A | 13427080 | 100% |  |  |  | MECH TECH [404.8 h]; ELEC TECH [36.8 h] | 19,008.68 | 19,008.68 | 0 | 19008.672 | BEVINS M | 1 | 1 | H | MIKE B |  |  |  |  |  |  |  |  |  |  |  |  |  |  |  | 6MON |  | 10-065 |  |  |  |  |  |  |  |  |  |  |  |  |  |  |  |  |  |  |  |  |  |  |  |  |
| 13427080 |  | BLEED UP VACUUM NORTH SIDE OF W/ARC |  | 2d | 2011-05-27 A | 2011-05-31 A | 13427075 | 100% |  |  |  | MECH TECH [20 h] | 861.4 | 861.4 | 0 | 861.4 | BEVINS M | 1 | 1 | H | MIKE B |  |  |  |  |  |  |  |  |  |  |  |  |  |  | BM TR 12GE | 6MON | W/A DIPOLES | 10-065 |  | 13427030 | W Arc Quad 2 Stack 8 |  |  |  |  |  |  |  |  |  |  |  |  |  |  |  |  |  |  |  |  |  |
| 13427145 |  | INSTALL MAGNETS AND ARC 10 - QUAD 2 |  | 19d | 2011-06-01 A | 2011-06-27 A | 13427140 FS-6d | 100% |  |  |  | ELEC TECH [73.6 h]; MECH TECH [920 h] | 42,772.27 | 42,772.27 | 0 | 42772.272 | BEVINS M | 1 | 1 | H | MIKE B |  |  |  |  |  |  |  |  |  |  |  |  |  |  | BM TR 12GE | 6MON | W/A DIPOLES | 10-065 |  |  |  |  |  |  |  |  |  |  |  |  |  |  |  |  |  |  |  |  |  |  |  |  |
| 13427160 |  | INSTALL MAGNETS AND ARC 10 - QUAD 3 |  | 54d | 2011-06-06 A | 2011-08-19 A | 13427155 FS-15d | 100% |  |  |  | ELEC TECH [73.6 h]; MECH TECH [920 h] | 42,772.27 | 42,772.27 | 0 | 42772.272 | BEVINS M | 1 | 1 | H | MIKE B |  |  |  |  |  |  |  |  |  |  |  |  |  |  | BM TR 12GE | 6MON | W/A DIPOLES | 10-065 |  |  |  |  |  |  |  |  |  |  |  |  |  |  |  |  |  |  |  |  |  |  |  |  |
| 13427165 |  | REMOVE MAGNETS - QUAD 4 |  | 6d | 2011-06-11 A | 2011-06-20 A | 13427150 FS-1d | 100% | 2011-06-13 | 2011-06-20 |  | ELEC TECH [36.8 h]; MECH TECH [404.8 h] | 19,008.68 | 19,008.68 | 0 | 19008.672 | BEVINS M | 1 | 1 | H | MIKE B |  |  |  |  |  |  |  |  |  |  |  |  |  |  |  | 6MON |  | 10-065 |  |  |  |  |  |  |  |  |  |  |  |  |  |  |  |  |  |  |  |  |  |  |  |  |
| 13427155 |  | REFURB, UPGRADE AND TEST MAGNETS - QUAD 3 |  | 16d | 2011-06-20 A | 2011-07-12 A | 13427150, 13427140 | 100% |  |  |  | MECH TECH [1545.6 h]; MSHOP | 80,437.73 | 66,568.99 | 0 | 80437.732 | BEVINS M | 1 | 1 | H | MIKE B |  |  |  |  |  |  |  |  |  |  |  |  |  |  | BM TR 12GE | 6MON | W/A DIPOLES | 10-065 |  |  |  |  |  |  |  |  |  |  |  |  |  |  |  |  |  |  |  |  |  |  |  |  |
| 13427170 |  | REFURB, UPGRADE AND TEST MAGNETS - QUAD 4 |  | 38d | 2011-06-22 A | 2011-08-15 A | 13427155 FS-35d, 13427165 | 100% |  |  |  | MSHOP; MECH TECH [1545.6 h] | 80,437.73 | 66,568.99 | 0 | 80437.732 | BEVINS M | 1 | 1 | H | MIKE B |  |  |  |  |  |  |  |  |  |  |  |  |  |  | BM TR 12GE | 6MON | W/A DIPOLES | 10-065 |  |  |  |  |  |  |  |  |  |  |  |  |  |  |  |  |  |  |  |  |  |  |  |  |
| 13427021 |  | Rework of arcs 5, 7, and 9 Part A FY12 |  | 69d | 2011-07-01 A | 2011-10-09 A | 2-02M FS-245d | 100% | 2011-07-01 | 2011-10-07 |  | MECH TECH [814.29 h] | 35,152.31 | 35,152.31 | 0 | 36187.0476 | BEVINS M | 1 | 1 | U | MIKE B |  |  | 08-016 | 09-012 |  |  |  |  |  |  |  |  |  |  |  |  |  | 10-065 |  |  |  | 07-024 | 11-052 | 12-035 | 12-053 |  |  |  |  |  |  |  |  |  |  |  |  |  |  |  |  |  |
| 13427021a |  | Rework of arcs 5, 7, and 9 Part A FY13 |  | 69d | 2011-07-01 A | 2011-10-09 A | 13427021 | 100% | 2011-07-01 | 2011-10-07 |  | MECH TECH [1085.71 h] | 46,869.31 | 46,869.31 | 0 | 49790.6606 | BEVINS M | 1 | 1 | U | MIKE B |  |  | 08-016 | 09-012 |  |  |  |  |  |  |  |  |  |  |  |  |  | 10-065 |  |  |  | 07-024 | 11-052 | 12-035 | 12-053 |  |  |  |  |  |  |  |  |  |  |  |  |  |  |  |  |  |
| 13427022 |  | Rework of arcs 5, 7, and 9 Part B FY12 |  | 36d | 2011-07-01 A | 2011-08-22 A | 2-02M FS-245d | 100% |  |  |  | MECH TECH [1662.5 h] | 71,603.88 | 71,603.88 | 0 | 73881.5 | BEVINS M | 1 | 1 | U | MIKE B |  |  | 08-016 | 09-012 |  |  |  |  |  |  |  |  |  |  |  |  |  | 10-065 |  |  |  | 07-024 | 11-052 |  | 12-053 |  |  |  |  |  |  |  |  |  |  |  |  |  |  |  |  |  |
| 13427022a |  | Rework of arcs 5, 7, and 9 Part B FY13 |  | 36d | 2011-07-01 A | 2011-08-22 A | 13427022 | 100% |  |  |  | MECH TECH [237.5 h] | 10,229.13 | 10,229.13 | 0 | 10891.75 | BEVINS M | 1 | 1 | U | MIKE B |  |  | 08-016 | 09-012 |  |  |  |  |  |  |  |  |  |  |  |  |  | 10-065 |  |  |  | 07-024 | 11-052 |  | 12-053 |  |  |  |  |  |  |  |  |  |  |  |  |  |  |  |  |  |
| 13427023 |  | Rework of arcs 5, 7, and 9 Part C FY12 |  | 16d | 2011-07-01 A | 2011-07-25 A | 2-02M FS+21d | 100% |  |  |  | MECH TECH [1038.85 h] | 44,743.27 | 44,743.27 | 0 | 46166.494 | BEVINS M | 1 | 1 | U | MIKE B |  |  | 08-016 | 09-012 |  |  |  |  |  |  |  |  |  |  |  |  |  | 10-065 |  |  |  | 07-024 | 11-052 |  | 12-053 |  |  |  |  |  |  |  |  |  |  |  |  |  |  |  |  |  |
| 13427023a |  | Rework of arcs 5, 7, and 9 Part C FY13 |  | 16d | 2011-07-01 A | 2011-07-25 A | 13427023 | 100% |  |  |  | MECH TECH [861.15 h] | 37,089.73 | 37,089.73 | 0 | 39492.339 | BEVINS M | 1 | 1 | U | MIKE B |  |  | 08-016 | 09-012 |  |  |  |  |  |  |  |  |  |  |  |  |  | 10-065 |  |  |  | 07-024 | 11-052 |  | 12-053 |  |  |  |  |  |  |  |  |  |  |  |  |  |  |  |  |  |
| 13427024 |  | Rework of arcs 5, 7, and 9 Part D FY12 |  | 16d | 2011-07-01 A | 2011-07-25 A | 2-02M FS+30d | 100% |  |  |  | MECH TECH [843.05 h] | 36,310.16 | 36,310.16 | 0 | 37465.142 | BEVINS M | 1 | 1 | U | MIKE B |  |  | 08-016 | 09-012 |  |  |  |  |  |  |  |  |  |  |  |  |  | 10-065 |  |  |  | 07-024 | 11-052 |  | 12-053 |  |  |  |  |  |  |  |  |  |  |  |  |  |  |  |  |  |
| 13427024a |  | Rework of arcs 5, 7, and 9 Part D FY13 |  | 16d | 2011-07-01 A | 2011-07-25 A | 13427024 | 100% |  |  |  | MECH TECH [1056.95 h] | 45,522.84 | 45,522.84 | 0 | 48471.727 | BEVINS M | 1 | 1 | U | MIKE B |  |  | 08-016 | 09-012 |  |  |  |  |  |  |  |  |  |  |  |  |  | 10-065 |  |  |  | 07-024 | 11-052 |  | 12-053 |  |  |  |  |  |  |  |  |  |  |  |  |  |  |  |  |  |
| 13427085 |  | PUMP OUT SOUTH SIDE WEST ARC |  | 1d | 2011-07-01 A | 2011-07-04 A | 13427145, 13427130 | 100% | 2011-07-01 | 2011-07-01 |  | MECH TECH [73.6 h] | 3,169.95 | 3,169.95 | 0 | 3169.952 | BEVINS M | 1 | 1 | H | MIKE B |  |  |  |  |  |  |  |  |  |  |  |  |  |  | BM TR 12GE | 6MON | W/A DIPOLES | 10-065 |  |  |  |  |  |  |  |  |  |  |  |  |  |  |  |  |  |  |  |  |  |  |  |  |
| 13427090 |  | QA CHECKS - SOUTH SIDE WEST ARC |  | 4d | 2011-07-03 A | 2011-07-08 A | 13427085 FS-1d | 100% | 2011-07-05 | 2011-07-08 |  | MECH TECH [128.8 h]; ELEC TECH [64.4 h] | 8,301.81 | 8,301.81 | 0 | 8301.804 | BEVINS M | 1 | 1 | H | MIKE B |  |  |  |  |  |  |  |  |  |  |  |  |  |  | BM TR 12GE | 6MON | W/A DIPOLES | 10-065 |  |  |  |  |  |  |  |  |  |  |  |  |  |  |  |  |  |  |  |  |  |  |  |  |
| 13427175 |  | INSTALL MAGNETS AND ARC 10 - QUAD 4 |  | 32d | 2011-07-04 A | 2011-08-17 A | 13427170 FS-7d | 100% | 2011-07-05 | 2011-08-17 |  | MECH TECH [818.8 h]; ELEC TECH [73.6 h] | 38,413.59 | 38,413.59 | 0 | 38413.588 | BEVINS M | 1 | 1 | H | MIKE B |  |  |  |  |  |  |  |  |  |  |  |  |  |  | BM TR 12GE | 6MON | W/A DIPOLES | 10-065 |  |  |  |  |  |  |  |  |  |  |  |  |  |  |  |  |  |  |  |  |  |  |  |  |
| 13427095 |  | 2B FINAL STACK ALIGNMENT (B/L UNDER VACUUM) - SOUTH SIDE WEST ARC |  | 7d | 2011-07-09 A | 2011-07-19 A | 13427090 | 100% | 2011-07-11 | 2011-07-19 |  | MECH TECH [220.8 h] | 9,509.86 | 9,509.86 | 0 | 9509.856 | BEVINS M | 1 | 1 | H | MIKE B |  |  |  |  |  |  |  |  |  |  |  |  |  |  | BM TR 12GE | 6MON | W/A DIPOLES | 10-065 |  |  |  |  |  |  |  |  |  |  |  |  |  |  |  |  |  |  |  |  |  |  |  |  |
| 13427105 |  | QA CHECKS - NORTH SIDE WEST ARC |  | 21d | 2011-07-19 A | 2011-08-16 A | 13427100 FS-40d | 100% |  |  |  | MECH TECH [128.8 h]; ELEC TECH [64.4 h] | 8,301.81 | 8,301.81 | 0 | 8301.804 | BEVINS M | 1 | 1 | H | MIKE B |  |  |  |  |  |  |  |  |  |  |  |  |  |  | BM TR 12GE | 6MON | W/A DIPOLES | 10-065 |  |  |  |  |  |  |  |  |  |  |  |  |  |  |  |  |  |  |  |  |  |  |  |  |
| 13427100 |  | PUMP OUT NORTH SIDE WEST ARC |  | 11d | 2011-08-01 A | 2011-08-15 A | 13427175, 13427160 | 100% |  |  |  | MECH TECH [73.6 h] | 3,169.95 | 3,169.95 | 0 | 3169.952 | BEVINS M | 1 | 1 | H | MIKE B |  |  |  |  |  |  |  |  |  |  |  |  |  |  | BM TR 12GE | 6MON | W/A DIPOLES | 10-065 |  |  |  |  |  |  |  |  |  |  |  |  |  |  |  |  |  |  |  |  |  |  |  |  |
| 13427110 |  | 2B FINAL STACK ALIGNMENT (B/L UNDER VACUUM) - NORTH SIDE WEST ARC |  | 3d | 2011-08-16 A | 2011-08-18 A | 13427105 FS-1d | 100% |  |  |  | MECH TECH [220.8 h] | 9,509.86 | 9,509.86 | 0 | 9509.856 | BEVINS M | 1 | 1 | H | MIKE B |  |  |  |  |  |  |  |  |  |  |  |  |  |  | BM TR 12GE | 6MON | W/A DIPOLES | 10-065 |  |  |  |  |  |  |  |  |  |  |  |  |  |  |  |  |  |  |  |  |  |  |  |  |
| 13427115M |  | WEST ARC FINISHED | milestone | 0d | 2011-09-08 A | 2011-09-08 A | 13427110, 13427095 | 100% | 2011-10-03 | 2011-10-03 |  |  |  |  |  | 0 | BEVINS M | 1 | 1 | M | MIKE B |  |  |  |  |  |  |  |  |  |  |  |  |  |  | BM TR 12GE | 6MON | W/A DIPOLES | 10-065 |  |  |  |  |  |  |  |  |  |  |  |  |  |  |  |  |  |  |  |  |  |  |  |  |
| 13427015LOE |  | Installation Team Engineering Support FY12 (12 Month Down) |  | 106d | 2012-05-01 A | 2012-09-28 A | 2-02M FS-5d | 100% |  |  |  | MECH DES [2240 h] | 107,900.8 | 107,900.8 | 0 | 107900.8 | BEVINS M | 1 | 1 | E | MIKE B |  |  |  |  |  |  |  |  |  |  | 17.9245283 | 82.07547169 | 100 | 100 |  |  |  | 10-065 |  |  |  |  |  | 12-035 |  | Install | 10-028 |  |  |  |  |  |  |  |  |  |  |  |  |  |  |  |
| 13427020 |  | Arcs 1 & 3 - Remove |  | 30d | 2012-06-05 A | 2012-07-16 A | 2-02M, 3A-14M | 100% |  |  |  | MECH TECH [392 h]; MECH ENG [284 h] | 37,334.56 | 37,334.56 | 0 | 37334.56 | BEVINS M | 1 | 1 | H | MIKE B |  |  | 08-016 | 09-012 |  |  |  |  |  |  |  |  |  |  |  |  |  | 10-065 |  |  |  | 07-024 | 11-052 | 12-035 |  |  |  |  |  |  |  |  |  |  |  |  |  |  |  |  |  |  |
| 13427025 |  | Arcs 1 & 3 - Refurb and measure FY12 |  | 73.85d | 2012-06-05 A | 2012-09-17 A | 2-02M FS+13d, 13427020 FS-35d | 100% |  |  |  | MECH TECH [694.86 h]; MECH ENG [290.04 h] | 51,217.18 | 51,217.18 | 0 | 51217.1832 | BEVINS M | 1 | 1 | U | MIKE B |  |  |  |  |  |  |  |  |  |  |  |  |  |  |  |  |  | 10-065 |  |  |  |  | 11-052 | 12-035 | 12-053 |  |  | 08-044 | OPC A |  |  |  |  |  |  |  |  |  |  |  |  |  |
| 13427025a |  | Arcs 1 & 3 - Refurb and measure FY13 |  | 74d | 2012-06-05 A | 2012-09-17 A | 13427025 FS-20d | 100% |  |  |  | MECH TECH [1097.14 h]; MECH ENG [457.96 h] | 80,869.06 | 80,869.06 | 0 | 83452.826 | BEVINS M | 1 | 1 | U | MIKE B |  |  |  |  |  |  |  |  |  |  |  |  |  |  |  |  |  | 10-065 |  |  |  |  | 11-052 | 12-035 | 12-053 |  |  | 08-044 |  |  |  |  |  |  |  |  |  |  |  |  |  |  |
| 13427027 |  | Arcs 1 & 3 - Install FY12 |  | 107d | 2012-07-16 A | 2012-12-17 A | 13427025a FS-98d | 100% | 2012-07-16 | 2012-12-14 |  | MECH TECH [699.2 h]; MECH ENG [277.75 h] | 51,348.24 | 51,354.76 | 0 | 50548.278 | BEVINS M | 1 | 1 | U | MIKE B |  |  | 08-016 | 09-012 |  |  |  |  |  |  |  |  |  |  |  |  |  | 10-065 |  |  |  | 07-024 | 11-052 | 12-035 | 12-053 |  |  |  | OPC A |  |  |  |  |  |  |  |  |  |  |  |  |  |
| 13427027a |  | Arcs 1 & 3 - Install FY13 |  | 107d | 2012-07-16 A | 2012-12-17 A | 13427027 FS-25d | 100% | 2012-07-16 | 2012-12-14 |  | MECH ENG [526.25 h]; MECH TECH [1324.8 h] | 97,290.47 | 97,304.77 | 0 | 98834.778 | BEVINS M | 1 | 1 | U | MIKE B |  |  | 08-016 | 09-012 |  |  |  |  |  |  |  |  |  |  |  |  |  | 10-065 |  |  |  | 07-024 | 11-052 | 12-035 | 12-053 |  |  |  |  |  |  |  |  |  |  |  |  |  |  |  |  |  |
| 13427030 |  | Arcs - Final align west end |  | 156d | 2012-07-23 A | 2013-08-30 A | 13427028 FS-150d, 13417020, 13458040 FS-250d, 13458010, 13458012 | 100% | 2012-07-23 | 2013-03-12 |  | MECH TECH [1384 h]; MECH ENG [312 h] | 85,209.74 | 85,575.28 | 4302.32799999 | 86046.56 | BEVINS M | 1 | 1 | U | MIKE B |  |  |  |  |  |  |  |  |  |  |  |  |  |  |  |  |  | 10-065 |  |  |  |  | 11-052 | 12-035 |  |  |  |  | OPC A | 12-028F |  |  |  |  |  |  |  |  |  |  |  |  |
| 13427032 |  | Arcs - Final align east end |  | 119d | 2012-08-20 A | 2013-04-15 A | 13427027a FS-30d | 100% | 2012-08-20 | 2013-02-14 |  | MECH ENG [160 h]; MECH TECH [720 h] | 44,260.3 | 44,346.53 | 0 | 44596.8 | BEVINS M | 1 | 1 | U | MIKE B |  |  |  |  |  |  |  |  |  |  |  |  |  |  |  |  |  | 10-065 |  |  |  |  | 11-052 | 12-035 |  |  |  |  | OPC A | 12-028F | XX |  |  |  |  |  |  |  |  |  |  |  |
| 13427016LOE |  | Installation Team Engineering Support FY13 (12 Month Down) |  | 237d | 2012-10-01 A | 2013-08-30 A | 13427015LOE | 100% | 2012-10-01 | 2013-09-13 |  | MECH DES [1731.65 h] | 86,080.32 | 86,080.32 | 11703.7224 | 86080.3215 | BEVINS M | 1 | 1 | E | MIKE B |  |  |  |  |  |  |  |  |  |  | 3.79746835 | 96.20253164 | 100 | 100 |  |  |  | 10-065 |  |  |  |  |  | 12-035 |  |  |  |  | OPC A |  |  |  |  |  |  |  |  |  |  |  |  |  |
| 13427028 |  | West Arc LCW Work |  | 60d | 2012-11-12 A | 2013-08-30 A | 9-130M | 100% | 2012-11-12 | 2013-02-14 |  | MECH TECH [436 h] | 19,994.96 | 19,994.96 | 9997.48 | 19994.96 | BEVINS M | 1 | 1 | H | MIKE B |  |  | 08-016 | 09-012 |  |  |  |  |  |  |  |  |  |  |  |  |  | 10-065 |  |  |  | 07-024 | 11-052 | 12-035 | 12-053 |  |  |  |  |  | XX | 13-003 |  |  |  |  |  |  |  |  |  |  |
| 13427061 |  | NE matching final alignment |  | 151d | 2012-11-12 A | 2013-08-30 A | 13417095 FS-200d | 100% | 2012-11-12 | 2013-06-25 |  | MECH ENG [32 h]; MECH TECH [144 h] | 8,919.36 | 8,919.36 | 4459.68 | 8919.36 | BEVINS M | 1 | 1 | H | MIKE B |  |  |  |  |  |  |  |  |  |  |  |  |  |  |  |  |  | 10-065 |  |  |  |  |  | 12-035 |  |  |  |  | OPC A |  |  |  |  |  |  |  |  |  |  |  |  |  |
| 13427062 |  | SW matching final alignment |  | 151d | 2012-11-12 A | 2013-08-30 A | 13463050 FS-160d | 100% | 2012-11-12 | 2013-06-25 |  | MECH TECH [144 h]; MECH ENG [32 h] | 8,919.36 | 8,919.36 | 4459.68 | 8919.36 | BEVINS M | 1 | 1 | H | MIKE B |  |  |  |  |  |  |  |  |  |  |  |  |  |  |  |  |  | 10-065 |  |  |  |  |  | 12-035 |  |  |  |  | OPC A |  |  |  | 13427062 | 12-018F | 12-029F |  |  |  |  |  |  |  |
| 13427035 |  | Hall A - Remove |  | 26d | 2013-02-01 A | 2013-02-11 A | 9-130M FS+8d | 100% | 2013-03-01 | 2013-04-05 |  | MECH TECH [144 h]; MECH ENG [32 h] | 8,919.36 | 8,919.36 | 0 | 8919.36 | BEVINS M | 1 | 1 | H | MIKE B |  |  |  |  |  |  |  |  |  |  |  |  |  |  |  |  |  | 10-065 |  |  |  |  | 11-052 | 12-035 |  |  |  |  | OPC A | 12-028F | XX |  | 13427035 |  |  |  |  |  |  |  |  |  |
| 13427042 |  | Hall B - Remove |  | 14d | 2013-02-02 A | 2013-03-11 A | 3A-17M, 13427035 FS-4d, 9-130M FS+43d | 100% | 2013-04-02 | 2013-04-19 |  | MECH TECH [480 h]; MECH ENG [108 h] | 29,827.68 | 29,827.68 | 0 | 29827.68 | BEVINS M | 1 | 1 | H | MIKE B |  |  |  |  |  |  |  |  |  |  |  |  |  |  |  |  |  | 10-065 |  |  |  |  |  | 12-035 |  |  |  | 08-044 | OPC A |  | XX |  | 13427042 |  |  | 08-029 |  |  |  |  |  |  |
| 13427050 |  | Hall C - Remove |  | 14d | 2013-03-01 A | 2013-03-18 A | 13427042 FS-9d, 3A-18M | 100% | 2013-04-01 | 2013-04-18 |  | MECH ENG [32 h]; MECH TECH [144 h] | 8,919.36 | 8,919.36 | 0 | 8919.36 | BEVINS M | 1 | 1 | H | MIKE B |  |  |  |  |  |  |  |  |  |  |  |  |  |  |  |  |  | 10-065 |  |  |  |  |  | 12-035 |  |  |  |  | OPC A |  | XX |  | 13427050 |  |  |  |  |  |  |  |  |  |
| 13427037 |  | Hall A - Upstairs |  | 22d | 2013-03-04 A | 2013-05-13 A | 13427035 | 100% | 2013-04-01 | 2013-04-30 |  | MECH TECH [424 h]; MECH ENG [96 h] | 26,391.2 | 26,391.2 | 0 | 26391.2 | BEVINS M | 1 | 1 | H | MIKE B |  |  |  |  |  |  |  |  |  |  |  |  |  |  |  |  |  | 10-065 |  |  |  |  | 11-052 | 12-035 |  |  |  |  | OPC A | 12-028F | XX |  | 13427037 |  |  |  |  |  |  |  |  |  |
| 13427045 |  | Hall B - Upstairs |  | 44d | 2013-03-04 A | 2013-08-30 A | 13427042 | 100% | 2013-04-19 | 2013-06-20 |  | MECH ENG [176 h]; MECH TECH [784 h] | 48,689.6 | 48,689.6 | 24344.8 | 48689.6 | BEVINS M | 1 | 1 | H | MIKE B |  |  |  |  |  |  |  |  |  |  |  |  |  |  |  |  |  | 10-065 |  |  |  |  |  | 12-035 |  |  |  |  | OPC A | 12-028 |  |  | 13427045 |  |  |  |  |  |  |  |  |  |
| 13427047 |  | Hall B - Install |  | 88d | 2013-06-01 A | 2013-08-30 A | 3A-38M, 13427045 FS-45d | 100% | 2013-07-01 | 2013-11-01 |  | MECH ENG [300 h]; MECH TECH [1336 h] | 83,697.93 | 82,976.96 | 82976.96 | 82976.96 | BEVINS M | 1 | 1 | S | MIKE B |  |  |  |  |  |  |  |  |  |  |  |  |  |  |  |  |  | 10-065 |  |  |  |  |  | 12-035 |  |  |  |  | OPC A | 12-028 |  |  | 13427047 |  |  |  | ST |  |  |  |  |  |
| 13427040 |  | Hall A - Install |  | 89d | 2013-07-01 A | 2013-08-30 A | 3A-37M, 13427037 FS-7d | 100% | 2013-08-01 | 2013-12-06 |  | MECH TECH [488 h]; MECH ENG [108 h] | 30,702.56 | 30,194.56 | 15097.28 | 30194.56 | BEVINS M | 1 | 1 | H | MIKE B |  |  |  |  |  |  |  |  |  |  |  |  |  |  |  |  |  | 10-065 |  |  |  |  |  | 12-035 |  |  |  | 08-044 | OPC A |  |  |  | 13427040 |  |  | 08-029 |  |  |  |  |  |  |
| 13427052 |  | Hall C - Upstairs |  | 26d | 2013-07-01 A | 2013-08-30 A | 13427050 | 100% | 2013-08-01 | 2013-09-06 |  | MECH ENG [104 h]; MECH TECH [472 h] | 29,171.36 | 29,171.36 | 14585.68 | 29171.36 | BEVINS M | 1 | 1 | H | MIKE B |  |  |  |  |  |  |  |  |  |  |  |  |  |  |  |  |  | 10-065 |  |  |  |  |  | 12-035 |  |  |  |  | OPC A |  |  |  | 13427052 |  |  |  |  |  |  |  |  |  |
| 13427057 |  | Hall C - Install |  | 28d | 2013-08-30 A | 2013-08-30 A | 13427052 FS-7d, 3A-33M | 100% | 2013-09-18 | 2013-10-25 |  | MECH ENG [120 h]; MECH TECH [528 h] | 33,608.48 | 32,897.28 | 32897.28 | 32897.28 | BEVINS M | 1 | 1 | H | MIKE B |  |  |  |  |  |  |  |  |  |  |  |  |  |  |  |  |  | 10-065 |  |  |  |  |  | 12-035 |  |  |  |  | OPC A |  |  |  | 13427057 |  |  |  |  |  |  |  |  |  |
| 13427185 |  | Re-Baseline Actuals Adjustment |  | 1d | 2013-08-30 A | 2013-08-30 A |  | 100% | 2013-09-03 | 2013-09-03 |  | PROCUREMENT>$50K 69 NO ESCALATION | 20,141.16 |  |  | 20141.16 |  |  |  |  |  |  |  |  |  |  | 0 | 20141.16 | 2014116 | 100 | ADJ |  |  |  |  |  |  |  |  |  |  |  |  |  |  |  |  |  |  |  |  |  |  |  |  |  |  |  |  |  |  |  |  |
| 23427016LOE |  | Installation Team Engineering Support FY13 (12 Month Down) |  | 54d | 2013-09-03 A | 2013-09-30 A | 9-130M FS+228d | 100% | 2013-10-01 | 2013-12-17 | 8/5 M-F w/JLAB Holidays ReBaseline | MECH DES [182.52 h] | 9,363.28 | 9,073.07 |  | 0 | BEVINS M | 1 | 1 | E | MIKE B |  |  |  |  |  |  |  |  |  |  | 62.96296296 | 37.03703703 | 100 | 100 |  |  |  | 10-065 |  |  |  |  |  | 12-035 |  |  |  |  |  |  |  |  |  |  |  |  |  | 23427016LOE | 9073.0692 | PE | 13-015 | PR |

Notes:
- 13427030: Entry Criteria: Ext Pred: Finish of magnet / measurement
- 13427032: Entry Criteria: Ext Pred: Finish of magnet / measurement
- 13427047: Steps: Hall B - Install (done)

| ID | WBS | Activity | Duration | Start | Finish | Predecessors | Complete | Remaining | Planned start | Planned finish | Total float | Free float | Calendar | Resources | Cost | Actual cost | Original Activity ID Rebaseline | MONTHLY EV COST | RESP - Responsibility | STRT%COMP for CM EVM | FNSH%COMP for CM EVM | EVMS Reporting Codes | CAM RESPONSIBLE | CR 08-029 | CR 08-044 | Activities with Steps | CR 10-065 | CR 12-035 | BOE Labor | CR 13-015 | Post Rebaseline | CR 14-001 | PRIOR MONTH EV COST | Remaining Material Cost Based on % Compl | Claimed Material Cost Based on % Complet | Initial Claimed Material Calc | Claimed Material Divider | Obligated Prior to Rebaseline | LOE % Pre Calc | LOE % | LOE Divider | LOE Multiplier | CR 12-028 | Calculated Remaining Total Cost | CR 09-012 | CR 11-001 | ReBaseline Actuals Adjustment | CR 10-030 |
| --- | --- | --- | --- | --- | --- | --- | --- | --- | --- | --- | --- | --- | --- | --- | --- | --- | --- | --- | --- | --- | --- | --- | --- | --- | --- | --- | --- | --- | --- | --- | --- | --- | --- | --- | --- | --- | --- | --- | --- | --- | --- | --- | --- | --- | --- | --- | --- | --- |
| 23427040 |  | Hall A - Install FY13 | 29d | 2013-09-03 A | 2013-11-27 | 9-130M FS+228d | 90% | 19d | 2013-10-01 | 2013-11-08 | 19d | 0d | 8/5 M-F w/JLAB Holidays ReBaseline | MECH TECH [208.34 h]; MECH ENG [50.32 h] | 13,615.96 | 9,307.71 | 23427040 | 11875.9894497 | BEVINS M | 1 | 1 | S | MIKE B | 08-029 | 08-044 | ST | 10-065 | 12-035 | PE | 13-015 | PR |  |  |  |  |  |  |  |  |  |  |  |  |  |  |  |  |  |
| 23427040a |  | Hall A - Install FY14 | 9d | 2013-09-03 A | 2013-11-27 | 23427040 FS-30d | 90% | 19d | 2013-10-01 | 2013-10-11 | 19d | 0d | 8/5 M-F w/JLAB Holidays ReBaseline | MECH TECH [93.76 h]; MECH ENG [22.64 h] | 6,127.33 | 4,188.57 | 23427040 | 5514.6046077 | BEVINS M | 1 | 1 | S | MIKE B | 08-029 | 08-044 | ST | 10-065 | 12-035 | PE | 13-015 | PR | 14-001 |  |  |  |  |  |  |  |  |  |  |  |  |  |  |  |  |
| 23427052 |  | Hall C - Upstairs FY13 | 27d | 2013-09-03 A | 2013-11-11 | 9-130M FS+228d | 90% | 7d | 2013-10-01 | 2013-11-06 | 22d | 3d | 8/5 M-F w/JLAB Holidays ReBaseline | MECH TECH [118.22 h]; MECH ENG [29.56 h] | 7,801.31 | 5,600.31 | 23427052 | 0 | BEVINS M | 1 | 1 | S | MIKE B |  |  | ST | 10-065 | 12-035 | PE | 13-015 | PR |  | 6804.38232 |  |  |  |  |  |  |  |  |  |  |  |  |  |  |  |
| 23427052a |  | Hall C - Upstairs FY14 | 7d | 2013-09-03 A | 2013-11-11 | 23427052 FS-10d | 90% | 7d | 2013-10-01 | 2013-10-09 | 22d | 3d | 8/5 M-F w/JLAB Holidays ReBaseline | MECH TECH [41.38 h]; MECH ENG [10.34 h] | 2,730.3 | 1,960 | 23427052 | 0 | BEVINS M | 1 | 1 | S | MIKE B |  |  | ST | 10-065 | 12-035 | PE | 13-015 | PR | 14-001 | 2457.26892 |  |  |  |  |  |  |  |  |  |  |  |  |  |  |  |
| 23427062 |  | Material Handling costs (Vehicle) | 54d | 2013-09-03 A | 2013-11-27 | 9-130M FS+228d | 67% | 19d | 2013-10-01 | 2013-12-17 | 74d | 0d | 8/5 M-F w/JLAB Holidays ReBaseline | PROCUREMENT<$50K 60 | 18,239.39 |  | 23427057 | 6201.3926 | BEVINS M | 1 | 1 | S | MIKE B |  |  | ST | 10-065 | 12-035 | PE | 13-015 | PR |  | 6018.9987 | 6018.9987 | 12220.3913 | 1222039.13 | 100 | OB |  |  |  |  |  |  |  |  |  |  |
| 23427016LOEa |  | Installation Team Engineering Support FY14 (12 Month Down) | 34d | 2013-10-01 A | 2013-11-15 | 23427016LOE | 68% | 11d | 2013-11-01 | 2013-12-20 | 96d | 34d | 8/5 M-F w/JLAB Holidays ReBaseline | MECH DES [310.29 h] | 15,917.88 | 10,767.98 | 23427016LOE | 10768.4437905 | BEVINS M | 1 | 1 | E | MIKE B |  |  |  | 10-065 | 12-035 | PE | 13-015 | PR | 14-001 |  |  |  |  |  |  | 32.35294117 | 67.64705882 | 100 | 100 |  |  |  |  |  |  |
| 23427047 |  | Hall B - Install FY13 | 20d | 2013-10-01 A | 2013-11-14 | 9-130M FS+228d | 80% | 10d | 2013-11-01 | 2013-12-02 | 28d | 0d | 8/5 M-F w/JLAB Holidays ReBaseline | MECH ENG [64.48 h]; MECH TECH [264.76 h] | 17,343.14 | 12,087.65 | 23427047 | 13446.113192 | BEVINS M | 1 | 1 | S | MIKE B |  |  | ST | 10-065 | 12-035 | PE | 13-015 | PR |  |  |  |  |  |  |  |  |  |  |  | 12-028 |  |  |  |  |  |
| 23427047a |  | Hall B - Install FY14 | 10d | 2013-10-01 A | 2013-11-14 | 23427047 FS-20d | 80% | 10d | 2013-12-03 | 2013-12-16 | 28d | 0d | 8/5 M-F w/JLAB Holidays ReBaseline | MECH ENG [96.72 h]; MECH TECH [397.15 h] | 26,015.23 | 18,131.83 | 23427047 | 20812.1883104 | BEVINS M | 1 | 1 | S | MIKE B |  |  | ST | 10-065 | 12-035 | PE | 13-015 | PR | 14-001 |  |  |  |  |  |  |  |  |  |  | 12-028 |  |  |  |  |  |
| 23427057 |  | Hall C - Install | 27d | 2013-10-01 A | 2013-11-27 | 23427052a FS-10d, 23427052 FS-10d | 80% | 19d | 2013-11-12 | 2013-12-20 | 19d | 0d | 8/5 M-F w/JLAB Holidays ReBaseline | MECH TECH [546 h]; MECH ENG [132 h] | 35,693.16 | 19,546.25 | 23427057 | 28554.528 | BEVINS M | 1 | 1 | S | MIKE B |  |  | ST | 10-065 | 12-035 | PE | 13-015 | PR | 14-001 |  |  |  |  |  |  |  |  |  |  |  |  |  |  |  |  |
| 23427067 |  | Material Handling costs DeObligation | 1d | 2013-10-21 A | 2013-10-28 A | 23427062 | 100% |  | 2014-01-02 | 2014-01-02 |  |  | 8/5 M-F w/JLAB Holidays ReBaseline | PROCUREMENT<$50K 60 | -10,319 |  | 23427057 | 0 | BEVINS M | 1 | 1 | D | MIKE B |  |  |  | 10-065 | 12-035 | PE | 13-015 | PR | 14-001 |  | 0 | -10319 | -1031900 | 100 |  |  |  |  |  |  |  |  |  |  |  |
|  | 3 | **1.3.4.3 LINACS** |  | 2009-12-21 | 2013-08-30 |  |  |  |  |  |  |  |  |  |  |  |  |  |  |  |  |  |  |  |  |  |  |  |  |  |  |  |  |  |  |  |  |  |  |  |  |  |  |  |  |  |  |  |
|  | 1 | **1.3.4.3.1 QUADRUPOLES** |  |  |  |  |  |  |  |  |  |  |  |  |  |  |  |  |  |  |  |  |  |  |  |  |  |  |  |  |  |  |  |  |  |  |  |  |  |  |  |  |  |  |  |  |  |  |
|  | 2 | **1.3.4.3.2 CORRECTORS** |  | 2009-12-21 | 2013-08-30 |  |  |  |  |  |  |  |  |  |  |  |  |  |  |  |  |  |  |  |  |  |  |  |  |  |  |  |  |  |  |  |  |  |  |  |  |  |  |  |  |  |  |  |
| 13432005 |  | Vend Fab H & V Linac Correctors (Linac Correctors) Labor FY10 | 451d | 2009-12-21 A | 2011-10-16 A | 121434999, 121432005, 13432004b | 100% |  | 2009-12-28 | 2011-10-14 |  |  |  | MECH DES [29.88 h]; MECH ENG [29.88 h] | 3,382.3 | 3,382.3 |  | 3319.3692 | BEVINS M | 1 | 1 | H | MIKE B | 08-029 |  |  |  |  |  |  |  |  |  |  |  |  |  |  |  |  |  |  |  | 0 | 09-012 | 11-001 |  |  |
| 13432005a |  | Vend Fab H & V Linac Correctors (Linac Correctors) Labor FY11 | 451d | 2009-12-21 A | 2011-10-15 A | 13432004b, 121434999, 121432005 | 100% |  | 2009-12-28 | 2011-10-14 |  |  |  | MECH DES [10.12 h]; MECH ENG [10.12 h] | 1,145.55 | 1,145.55 |  | 1160.0556 | BEVINS M | 1 | 1 | H | MIKE B | 08-029 |  |  |  |  |  |  |  |  |  |  |  |  |  |  |  |  |  |  |  | 0 | 09-012 | 11-001 |  |  |
| 13432005b |  | Vend Fab H & V Linac Correctors (Linac Correctors) Procurement | 451d | 2009-12-21 A | 2011-10-15 A | 13432004b, 121432005, 121434999 | 100% |  | 2009-12-28 | 2011-10-14 |  |  |  | PROCUREMENT<$50K 60 NO ESCALATION FY11 | 20,595.41 |  |  | 20595.413487 | BEVINS M | 1 | 1 | H | MIKE B | 08-029 |  |  |  |  |  |  |  |  |  | 0 | 20595.413487 | 2059541.3487 | 100 |  |  |  |  |  |  | 0 | 09-012 | 11-001 |  |  |
| 13432015 |  | Mag Measurement of Linac Correctors & Skew Quads (Linac Correctors) | 6d | 2011-12-12 A | 2011-12-19 A | 13432005, 13432005b, 13432005a | 100% |  |  |  |  |  |  | MECH ENG [8 h]; MECH TECH [164 h] | 7,849.12 | 7,849.12 |  | 7607.08 | BEVINS M | 1 | 1 | H | MIKE B |  |  |  |  |  |  |  |  |  |  |  |  |  |  |  |  |  |  |  |  | 0 |  |  |  |  |
| 13432020 |  | Re-Baseline Actuals Adjustment | 1d | 2013-08-30 A | 2013-08-30 A |  | 100% |  | 2013-09-03 | 2013-09-03 |  |  |  | PROCUREMENT>$50K 69 NO ESCALATION | 11,763.44 |  |  | 11763.44 |  |  |  |  |  |  |  |  |  |  |  |  |  |  |  | 0 | 11763.44 | 1176344 | 100 |  |  |  |  |  |  |  |  |  | ADJ |  |
|  | 3 | **1.3.4.3.3 STANDS** |  | 2010-08-16 | 2013-08-30 |  |  |  |  |  |  |  |  |  |  |  |  |  |  |  |  |  |  |  |  |  |  |  |  |  |  |  |  |  |  |  |  |  |  |  |  |  |  |  |  |  |  |  |
| 13434005 |  | Proc Prep Linac Girders (Linac Girders) FY10 | 64.63d | 2010-08-16 A | 2010-11-15 A | 121434005, 121434999, 9-100M FS+215d | 100% |  |  |  |  |  |  | MECH ENG [44.75 h]; MECH DES [44.75 h] | 5,048.81 | 5,048.81 |  | 4971.2775 | BEVINS M | 1 | 1 | H | MIKE B |  |  |  | 10-065 |  |  |  |  |  |  |  |  |  |  |  |  |  |  |  |  | 0 |  | 11-001 |  | 10-030 |
| 13434005a |  | Proc Prep Linac Girders (Linac Girders) FY11 | 65d | 2010-08-16 A | 2010-11-15 A | 121434005, 9-100M FS+215d, 121434999 | 100% |  |  |  |  |  |  | MECH DES [35.25 h]; MECH ENG [35.25 h] | 3,977.36 | 3,977.36 |  | 4040.7075 | BEVINS M | 1 | 1 | H | MIKE B |  |  |  | 10-065 |  |  |  |  |  |  |  |  |  |  |  |  |  |  |  |  | 0 |  | 11-001 |  | 10-030 |
| 13433005 |  | Proc Prep Linac Stands (Linac Stands) | 46d | 2010-09-13 A | 2010-11-15 A | 121434999, 121434005, 9-110M | 100% |  |  |  |  |  |  | MECH ENG [80 h]; MECH DES [20 h] | 6,309.7 | 6,309.7 |  | 6369.6 | BEVINS M | 1 | 1 | H | MIKE B |  |  |  | 10-065 |  |  |  |  |  |  |  |  |  |  |  |  |  |  |  |  | 0 |  |  |  | 10-030 |
| 13433010 |  | Vend Fab Linac Stands (Linac Stands) | 66d | 2010-11-15 A | 2011-02-28 A | 13433005 | 100% |  |  |  |  |  |  | PROCUREMENT<$50K 60 | 14,962.55 |  |  | 14962.55 | BEVINS M | 1 | 1 | D | MIKE B |  |  |  | 10-065 |  |  |  |  |  |  | 0 | 14962.55 | 1496255 | 100 |  |  |  |  |  |  | 0 |  |  |  | 10-030 |
| 13434006 |  | Vend Fab Linac Girders (Linac Girders) | 81d | 2010-11-15 A | 2011-03-21 A | 13434005, 13434005a | 100% |  |  |  |  |  |  | PROCUREMENT<$50K 60 | 92,871 |  |  | 92871 | BEVINS M | 1 | 1 | D | MIKE B |  |  |  | 10-065 |  |  |  |  |  |  | 0 | 92871 | 9287100 | 100 |  |  |  |  |  |  | 0 |  |  |  | 10-030 |
| 13434007 |  | Receive and Inspect Linac Girders (Linac Girders) | 48d | 2011-01-17 A | 2011-03-25 A | 13434006 FS-40d | 100% |  | 2011-01-18 | 2011-03-25 |  |  |  | MECH TECH [8 h] | 344.56 | 344.56 |  | 344.56 | BEVINS M | 1 | 1 | U | MIKE B |  |  |  | 10-065 |  |  |  |  |  |  |  |  |  |  |  |  |  |  |  |  | 0 |  |  |  | 10-030 |
| 13433015 |  | Receive and Inspect Linac Stands (Linac Stands) | 34d | 2011-02-01 A | 2011-03-21 A | 13433010 FS-9d | 100% |  |  |  |  |  |  | MECH TECH [40 h] | 1,722.8 | 1,722.8 |  | 1722.8 | BEVINS M | 1 | 1 | U | MIKE B |  |  |  | 10-065 |  |  |  |  |  |  |  |  |  |  |  |  |  |  |  |  | 0 |  |  |  | 10-030 |
| 13433020 |  | Re-Baseline Actuals Adjustment | 1d | 2013-08-30 A | 2013-08-30 A |  | 100% |  | 2013-09-03 | 2013-09-03 |  |  |  | PROCUREMENT>$50K 69 NO ESCALATION | 2,268.37 |  |  | 2268.37 |  |  |  |  |  |  |  |  |  |  |  |  |  |  |  | 0 | 2268.37 | 226837 | 100 |  |  |  |  |  |  |  |  |  | ADJ |  |

Notes:
- 23427040: Steps: Install Dipoles (done); reconnect lcw (done); Align for hookup (done); Install 9th dipole (done); Install passthrough dipole; Vacuum connect and leakcheck (done); Final align
- 23427040a: Steps: Install Dipoles (done); reconnect lcw (done); Align for hookup (done); Install 9th dipole (done); Install passthrough dipole; Vacuum connect and leakcheck (done); Final align
- 23427052: Steps: Refurb dipoles (done); Measure dipoles (done); Rebuild girders
- 23427052a: Steps: Refurb dipoles (done); Measure dipoles (done); Rebuild girders
- 23427062: Steps: Sept (done); Oct (done); Nov
- 23427047: Steps: Install dipoles (done); Install girders (done); reconnect lcw (done); Align for hookup; Vacuum connect and leakcheck; Rebuild girders; Final align
- 23427047a: Steps: Install dipoles (done); Install girders (done); reconnect lcw (done); Align for hookup; Vacuum connect and leakcheck; Rebuild girders; Final align
- 23427057: Steps: Install dipoles (done); Reconnect lcw (done); Complete dipole installation; Align for hookup (done); Vacuum connect and leakcheck; Final align

| ID | WBS | Activity | Duration | Start | Finish | Predecessors | Complete | Planned start | Planned finish | Resources | Cost | Actual cost | Remaining Material Cost Based on % Compl | Claimed Material Cost Based on % Complet | Initial Claimed Material Calc | Claimed Material Divider | Calculated Remaining Total Cost | MONTHLY EV COST | RESP - Responsibility | STRT%COMP for CM EVM | FNSH%COMP for CM EVM | EVMS Reporting Codes | CAM RESPONSIBLE | CR 10-030 | CR 10-065 | CR 08-016 | CR 09-012 | ReBaseline Actuals Adjustment | Activities with Steps | CR 11-012 | CR 12-035 | OPC Allison | CR 13-003 | CR 08-029 | CR 10-001 | CR 11-001 | MARCH!!! |
| --- | --- | --- | --- | --- | --- | --- | --- | --- | --- | --- | --- | --- | --- | --- | --- | --- | --- | --- | --- | --- | --- | --- | --- | --- | --- | --- | --- | --- | --- | --- | --- | --- | --- | --- | --- | --- | --- |
|  | 4 | **1.3.4.3.4 GIRDERS** |  |  |  |  |  |  |  |  |  |  |  |  |  |  |  |  |  |  |  |  |  |  |  |  |  |  |  |  |  |  |  |  |  |  |  |
|  | 5 | **1.3.4.3.5 VACUUM** |  | 2011-02-14 | 2013-08-30 |  |  |  |  |  |  |  |  |  |  |  |  |  |  |  |  |  |  |  |  |  |  |  |  |  |  |  |  |  |  |  |  |
| 13435010 |  | Proc New DI Ion Pumps (Linac Vac) | 50d | 2011-02-14 A | 2011-04-25 A | 9-110M FS-10d | 100% |  |  | PROCUREMENT<$50K 60 NO ESCALATION FY11 | 21,316.43 |  | 0 | 21316.43 | 2131643 | 100 | 0 | 21316.43 | BEVINS M | 1 | 1 | D | MIKE B | 10-030 | 10-065 |  |  |  |  |  |  |  |  |  |  |  |  |
| 13435015 |  | Rebuild 3 South Linac Girders (Linac Vac) | 35d | 2011-04-11 A | 2011-05-29 A | 13436020 FS-20d | 100% | 2011-04-11 | 2011-05-27 | PROCUREMENT<$50K 60; MECH ENG [10 h]; MECH TECH [210 h]; MECH DES [20 h] | 11,276.94 | 10,657.8 | 0 | 619.14 | 61914 | 100 | 0 | 11276.94 | BEVINS M | 1 | 1 | U | MIKE B | 10-030 | 10-065 | 08-016 | 09-012 |  |  |  |  |  |  |  |  |  |  |
| 13435020 |  | Re-Baseline Actuals Adjustment | 1d | 2013-08-30 A | 2013-08-30 A |  | 100% | 2013-09-03 | 2013-09-03 | PROCUREMENT>$50K 69 NO ESCALATION | -6,040.98 |  |  |  |  | 100 |  |  |  |  |  |  |  |  |  |  |  | ADJ |  |  |  |  |  |  |  |  |  |
|  | 6 | **1.3.4.3.6 INSTALLATION** |  | 2011-05-16 | 2013-08-30 |  |  |  |  |  |  |  |  |  |  |  |  |  |  |  |  |  |  |  |  |  |  |  |  |  |  |  |  |  |  |  |  |
| 13436020 |  | Remove Warm Girder SL22 | 6d | 2011-05-16 A | 2011-05-23 A | 4A-01M | 100% |  |  | MECH TECH [80 h] | 3,445.6 | 3,445.6 |  |  |  |  | 0 | 3445.6 | BEVINS M | 1 | 1 | H | MIKE B |  | 10-065 |  |  |  | NB |  |  |  |  |  |  |  |  |
| 13436030 |  | Remove Warm Girder SL23 | 6d | 2011-05-16 A | 2011-05-23 A | 13436025 | 100% |  |  | MECH TECH [80 h] | 3,445.6 | 3,445.6 |  |  |  |  | 0 | 3445.6 | BEVINS M | 1 | 1 | H | MIKE B |  | 10-065 |  |  |  | NB |  |  |  |  |  |  |  |  |
| 13436025 |  | Reinstall Warm Girder SL22 | 11d | 2011-08-01 A | 2011-08-15 A | 13435015, 131501000 FS+1d | 100% |  |  | MECH TECH [120 h] | 5,168.4 | 5,168.4 |  |  |  |  | 0 | 5168.4 | BEVINS M | 1 | 1 | H | MIKE B |  | 10-065 |  |  |  | NB |  |  |  |  |  |  |  |  |
| 13436035 |  | Reinstall Warm Girder SL23 | 6d | 2011-08-08 A | 2011-08-15 A | 131502000 | 100% |  |  | MECH TECH [120 h] | 5,168.4 | 5,168.4 |  |  |  |  | 0 | 5168.4 | BEVINS M | 1 | 1 | H | MIKE B |  | 10-065 |  |  |  | NB | 11-012 |  |  |  |  |  |  |  |
| 13436040 |  | SL - remove girders | 8d | 2012-05-18 A | 2012-05-30 A | 2-02M FS+5d | 100% |  |  | MECH TECH [176 h]; MECH ENG [128 h] | 16,796.8 | 16,796.8 |  |  |  |  | 0 | 16796.8 | BEVINS M | 1 | 1 | H | MIKE B |  | 10-065 |  |  |  |  |  | 12-035 |  |  |  |  |  |  |
| 13436045 |  | NL - remove girders | 8d | 2012-05-18 A | 2012-05-30 A | 13436040 | 100% |  |  | MECH TECH [312 h]; MECH ENG [224 h] | 29,572.16 | 29,572.16 |  |  |  |  | 0 | 29572.16 | BEVINS M | 1 | 1 | H | MIKE B |  | 10-065 |  |  |  |  |  | 12-035 |  |  |  |  |  |  |
| 13436050 |  | SL - rebuild girders | 8d | 2012-05-18 A | 2012-05-30 A | 2-02M FS+5d, 13436040 FS-9d | 100% |  |  | MECH ENG [12 h]; MECH TECH [16 h] | 1,552.48 | 1,552.48 |  |  |  |  | 0 | 1552.48 | BEVINS M | 1 | 1 | H | MIKE B |  | 10-065 |  |  |  |  |  | 12-035 |  |  |  |  |  |  |
| 13436055 |  | NL - rebuild girders | 8d | 2012-05-18 A | 2012-05-30 A | 13436045 | 100% |  |  | MECH TECH [192 h]; MECH ENG [140 h] | 18,349.28 | 18,349.28 |  |  |  |  | 0 | 18349.28 | BEVINS M | 1 | 1 | H | MIKE B |  | 10-065 |  |  |  |  |  | 12-035 |  |  |  |  |  |  |
| 13436060 |  | SL final alignment | 152d | 2012-09-10 A | 2013-06-17 A | 13417045 FS-125d | 100% | 2012-09-10 | 2013-04-23 | MECH TECH [360 h]; MECH ENG [80 h] | 22,230.27 | 22,243.89 |  |  |  |  | 0 | 22298.4 | BEVINS M | 1 | 1 | S | MIKE B |  | 10-065 |  |  |  | ST |  | 12-035 | OPC A | 13-003 |  |  |  |  |
| 13436065 |  | NL final alignment | 197d | 2012-09-10 A | 2013-06-17 A | 13417070 FS-170d | 100% | 2012-09-10 | 2013-06-26 | MECH TECH [360 h]; MECH ENG [80 h] | 22,245.84 | 22,243.89 |  |  |  |  | 0 | 22298.4 | BEVINS M | 1 | 1 | S | MIKE B |  | 10-065 |  |  |  | ST |  | 12-035 | OPC A |  |  |  |  |  |
| 13436070 |  | Re-Baseline Actuals Adjustment | 1d | 2013-08-30 A | 2013-08-30 A |  | 100% | 2013-09-03 | 2013-09-03 | PROCUREMENT>$50K 69 NO ESCALATION | -9,788.69 |  |  |  |  | 100 |  |  |  |  |  |  |  |  |  |  |  | ADJ |  |  |  |  |  |  |  |  |  |
|  | 4 | **1.3.4.4 INJECTOR & RE-INJECTION** |  | 2009-01-02 | 2013-10-21 |  |  |  |  |  |  |  |  |  |  |  |  |  |  |  |  |  |  |  |  |  |  |  |  |  |  |  |  |  |  |  |  |
|  | 1 | **1.3.4.4.1 DIPOLES** |  | 2009-07-01 | 2013-08-30 |  |  |  |  |  |  |  |  |  |  |  |  |  |  |  |  |  |  |  |  |  |  |  |  |  |  |  |  |  |  |  |  |
| 13441004 |  | Proc Prep for Chicane Dipoles (INJ/REINJ Dipoles) FY09 | 119d | 2009-07-01 A | 2009-12-21 A | 9-090M FS+185d | 100% | 2009-07-01 | 2009-12-18 | MECH ENG [28.24 h]; MECH DES [28.24 h] | 3,084.93 | 3,084.93 |  |  |  |  | 0 | 3040.036 | BEVINS M | 1 | 1 | H | MIKE B |  |  |  |  |  |  |  |  |  |  | 08-029 | 10-001B |  |  |
| 13441004b |  | Proc Prep for Chicane Dipoles (INJ/REINJ Dipoles) FY10 | 55d | 2009-10-01 A | 2009-12-21 A | 13441004 FS-300d | 100% | 2009-10-01 | 2009-12-18 | MECH ENG [23.76 h]; MECH DES [23.76 h] | 2,639.5 | 2,639.5 |  |  |  |  | 0 | 2639.4984 | BEVINS M | 1 | 1 | H | MIKE B |  |  |  |  |  |  |  |  |  |  |  | 10-001B |  |  |
| 13441005 |  | Vend Fab New Chicane Dipoles (INJ/REINJ Dipoles) Labor FY10 | 451.88d | 2009-12-21 A | 2011-10-17 A | 13441004b, 121441010a | 100% | 2009-12-28 | 2011-10-17 | MECH ENG [161.38 h]; MECH DES [11.95 h] | 11,380.35 | 11,380.35 |  |  |  |  | 0 | 11167.491 | BEVINS M | 1 | 1 | D | MIKE B |  |  |  | 09-012 |  |  |  |  |  |  | 08-029 |  | 11-001 |  |
| 13441005a |  | Vend Fab New Chicane Dipoles (INJ/REINJ Dipoles) Labor FY11 | 452d | 2009-12-21 A | 2011-10-17 A | 13441004b, 121441010a | 100% | 2009-12-28 | 2011-10-17 | MECH DES [4.05 h]; MECH ENG [54.62 h] | 3,852.05 | 3,852.05 |  |  |  |  | 0 | 3900.483 | BEVINS M | 1 | 1 | D | MIKE B |  |  |  | 09-012 |  |  |  |  |  |  | 08-029 |  | 11-001 |  |
| 13441005b |  | Vend Fab New Chicane Dipoles (INJ/REINJ Dipoles) Procurement | 452d | 2009-12-21 A | 2011-10-17 A | 121441010a, 13441004b | 100% | 2009-12-28 | 2011-10-17 | PROCUREMENT<$50K 60 NO ESCALATION FY11 | 38,889.68 |  | 0 | 38889.679655 | 3888967.9655 | 100 | 0 | 38889.679655 | BEVINS M | 1 | 1 | D | MIKE B |  |  |  | 09-012 |  |  |  |  |  |  | 08-029 |  | 11-001 |  |
| 13441010 |  | Mag Measurement of Chicane Dipoles (INJ/REINJ Dipoles) | 54d | 2012-10-01 A | 2013-07-15 A | 9-130M, 9-110M FS+130d, 13441005b, 9-120M FS+135d, 13441005, 13441005a | 100% | 2012-10-01 | 2012-12-17 | MECH TECH [20 h]; MECH ENG [12 h] | 1,785.52 | 1,785.52 |  |  |  |  | 0 | 1676.8 | BEVINS M | 1 | 1 | H | MIKE B |  |  |  |  |  |  |  |  |  |  | 08-029 |  |  | XX |
| 13441015 |  | Re-Baseline Actuals Adjustment | 1d | 2013-08-30 A | 2013-08-30 A |  | 100% | 2013-09-03 | 2013-09-03 | PROCUREMENT>$50K 69 NO ESCALATION | -28,930.61 |  |  |  |  | 100 |  |  |  |  |  |  |  |  |  |  |  | ADJ |  |  |  |  |  |  |  |  |  |

Notes:
- 13436020: Explanation: Successor to be installation of Cryo Module #1 once built / on Hogan ETC CR10-064
- 13436030: Explanation: Successor to be installation of Cryo Module #2 once built / on Hogan ETC CR10-064
- 13436025: Explanation: Successor to be commiss ioningof Cryo Module 1 / once built on Hogan ETC CR10-064
- 13436035: Explanation: Successor to be commiss ioningof Cryo Module #2 once / built on Hogan ETC CR10-064
- 13436060: Steps: Final Align South Part 1 (done); Final Align South Part 2 (done)
- 13436065: Steps: Final Align North Part 1 (done); Final Align North Part 2 (done)

| ID | WBS | Activity | Duration | Start | Finish | Predecessors | Complete | Planned start | Planned finish | Calendar | Resources | Cost | Actual cost | LOE Divider | LOE Multiplier | Calculated Remaining Total Cost | MONTHLY EV COST | RESP - Responsibility | STRT%COMP for CM EVM | FNSH%COMP for CM EVM | EVMS Reporting Codes | CAM RESPONSIBLE | CR 08-058 | CR 10-030 | CR 12-035 | Remaining Material Cost Based on % Compl | Claimed Material Cost Based on % Complet | Initial Claimed Material Calc | Claimed Material Divider | CR 10-065 | CR 11-057 | ReBaseline Actuals Adjustment | Profile change | Specification | MARCH!!! | OPC Allison | CR 12-053 | Original Activity ID Rebaseline | PRIOR MONTH EV COST | Activities with Steps | BOE Labor | CR 13-015 | Post Rebaseline |
| --- | --- | --- | --- | --- | --- | --- | --- | --- | --- | --- | --- | --- | --- | --- | --- | --- | --- | --- | --- | --- | --- | --- | --- | --- | --- | --- | --- | --- | --- | --- | --- | --- | --- | --- | --- | --- | --- | --- | --- | --- | --- | --- | --- |
|  | 2 | **1.3.4.4.2 QUADRUPOLES** |  |  |  |  |  |  |  |  |  |  |  |  |  |  |  |  |  |  |  |  |  |  |  |  |  |  |  |  |  |  |  |  |  |  |  |  |  |  |  |  |  |
|  | 3 | **1.3.4.4.3 CORRECTORS** |  |  |  |  |  |  |  |  |  |  |  |  |  |  |  |  |  |  |  |  |  |  |  |  |  |  |  |  |  |  |  |  |  |  |  |  |  |  |  |  |  |
|  | 4 | **1.3.4.4.4 STANDS** |  | 2009-01-02 | 2013-08-30 |  |  |  |  |  |  |  |  |  |  |  |  |  |  |  |  |  |  |  |  |  |  |  |  |  |  |  |  |  |  |  |  |  |  |  |  |  |  |
| 13444909LOE |  | FY09 Mngmnt/Planning for Reinjection Modifications (INJ/RE-INJ Stands) | 189d | 2009-01-02 A | 2009-09-30 A | 13444909LOEXD | 100% |  |  |  | SR STAFF [152.42 h]; MECH DES [121.94 h] | 21,020.72 | 21,020.72 | 100 | 100 | 0 | 21020.7224 | BEVINS M | 1 | 1 | E | MIKE B | 08-058 |  |  |  |  |  |  |  |  |  |  |  |  |  |  |  |  |  |  |  |  |
| 13444015 |  | Proc Prep New ReInjection Stands (INJ/RE-INJ Stands) | 271d | 2010-11-15 A | 2011-12-19 A | 121444015, 9-110M FS+172d | 100% |  |  |  | MECH ENG [48 h]; MECH DES [36 h] | 4,973.53 | 4,973.53 |  |  | 0 | 4942.08 | BEVINS M | 1 | 1 | H | MIKE B |  | 10-030 | 12-035F |  |  |  |  |  |  |  |  |  |  |  |  |  |  |  |  |  |  |
| 13444020 |  | Proc Alignment Cartridges (INJ/RE-INJ Stands) | 66d | 2010-11-15 A | 2011-02-28 A | 9-110M FS+45d, 121444015 | 100% |  |  |  | MECH DES [8 h]; PROCUREMENT<$50K 60 | 1,393.9 | 373.44 |  |  | 0 | 1393.9 | BEVINS M | 1 | 1 | H | MIKE B |  |  |  | 0 | 1020.46 | 102046 | 100 |  |  |  |  |  |  |  |  |  |  |  |  |  |  |
| 13445005 |  | Proc/Vend Fab New Girder for Chicane (INJ/RE-INJ Girders) | 85d | 2010-11-15 A | 2011-03-25 A | 9-100M FS+213d | 100% |  |  |  | PROCUREMENT<$50K 60 NO ESCALATION FY11 | 14,723.73 |  |  |  | 0 | 14723.73 | BEVINS M | 1 | 1 | D | MIKE B |  | 10-030 |  | 0 | 14723.73 | 1472373 | 100 |  |  |  |  |  |  |  |  |  |  |  |  |  |  |
| 13444025 |  | Procurem/Vend Fab Modifications for Spectrometer (INJ/RE-INJ Stands) | 19d | 2011-03-01 A | 2011-03-25 A | 121444020, 9-110M FS+80d | 100% |  |  |  | MECH TECH [40 h]; MECH ENG [80 h]; MECH DES [160 h]; PROCUREMENT<$50K 60 | 48,642.7 | 14,627.6 |  |  | 0 | 48642.7 | BEVINS M | 1 | 1 | D | MIKE B |  |  |  | 0 | 34015.1 | 3401510 | 100 |  |  |  |  |  |  |  |  |  |  |  |  |  |  |
| 13444017 |  | Vend Fab New ReInjection Stands (INJ/RE-INJ Stands) | 78d | 2011-12-19 A | 2012-04-16 A | 9-120M, 13444015 | 100% |  |  |  | PROCUREMENT<$50K 60 | 6,388.91 |  |  |  | 0 | 6388.91 | BEVINS M | 1 | 1 | D | MIKE B |  | 10-030 | 12-035F | 0 | 6388.91 | 638891 | 100 | 10-065 | 11-057 |  |  |  |  |  |  |  |  |  |  |  |  |
| 13444018 |  | Receive and Inspect New ReInjection Stands (INJ/RE-INJ Stands) | 53d | 2012-02-01 A | 2012-04-16 A | 13444017 FS-70d | 100% |  |  |  | MECH TECH [16 h] | 711.04 | 711.04 |  |  | 0 | 711.04 | BEVINS M | 1 | 1 | U | MIKE B |  | 10-030 | 12-035F |  |  |  |  | 10-065 | 11-057 |  |  |  |  |  |  |  |  |  |  |  |  |
| 13444950 |  | Re-Baseline Actuals Adjustment | 1d | 2013-08-30 A | 2013-08-30 A |  | 100% | 2013-09-03 | 2013-09-03 |  | PROCUREMENT>$50K 69 NO ESCALATION | -986.18 |  |  |  |  |  |  |  |  |  |  |  |  |  |  |  |  | 100 |  |  | ADJ |  |  |  |  |  |  |  |  |  |  |  |
|  | 5 | **1.3.4.4.5 GIRDERS** |  |  |  |  |  |  |  |  |  |  |  |  |  |  |  |  |  |  |  |  |  |  |  |  |  |  |  |  |  |  |  |  |  |  |  |  |  |  |  |  |  |
|  | 6 | **1.3.4.4.6 VACUUM** |  | 2011-09-01 | 2013-08-30 |  |  |  |  |  |  |  |  |  |  |  |  |  |  |  |  |  |  |  |  |  |  |  |  |  |  |  |  |  |  |  |  |  |  |  |  |  |  |
| 13446010 |  | Proc Prep New Vac Chambers (INJ/RE-INJ Vac) | 51d | 2011-09-01 A | 2011-11-13 A | 121446999, 9-110M FS+125d, 9-120M, 121446005 | 100% | 2011-09-01 | 2011-11-11 |  | MECH ENG [80 h]; MECH DES [40 h] | 7,440.38 | 7,440.38 |  |  | 0 | 7303.2 | BEVINS M | 1 | 1 | H | MIKE B |  | 10-030 |  |  |  |  |  |  | 11-057 |  | C |  |  |  |  |  |  |  |  |  |  |
| 13446010a |  | Vend Fab New Vac Chambers (INJ/RE-INJ Vac) | 61d | 2011-11-14 A | 2012-02-20 A | 9-120M FS+30d, 13446010 | 100% | 2011-11-14 | 2012-02-17 |  | PROCUREMENT<$50K 60 | 5,856.5 |  |  |  | 0 | 5856.5 | BEVINS M | 1 | 1 | D | MIKE B |  | 10-030 |  | 0 | 5856.5 | 585650 | 100 |  | 11-057 |  | C |  |  |  |  |  |  |  |  |  |  |
| 13446010b |  | Receive and Inspect New Vac Chambers (INJ/RE-INJ Vac) | 19d | 2012-02-01 A | 2012-02-28 A | 13446010a FS-10d | 100% |  |  |  | MECH ENG [8 h]; MECH TECH [8 h] | 916.48 | 916.48 |  |  | 0 | 916.48 | BEVINS M | 1 | 1 | U | MIKE B |  | 10-030 |  |  |  |  |  |  | 11-057 |  | C |  |  |  |  |  |  |  |  |  |  |
| 13446015 |  | Re-Baseline Actuals Adjustment | 1d | 2013-08-30 A | 2013-08-30 A |  | 100% | 2013-09-03 | 2013-09-03 |  | PROCUREMENT>$50K 69 NO ESCALATION | -6,126.26 |  |  |  |  |  |  |  |  |  |  |  |  |  |  |  |  | 100 |  |  | ADJ |  |  |  |  |  |  |  |  |  |  |  |
|  | 7 | **1.3.4.4.7 INSTALLATION** |  | 2012-05-18 | 2013-10-21 |  |  |  |  |  |  |  |  |  |  |  |  |  |  |  |  |  |  |  |  |  |  |  |  |  |  |  |  |  |  |  |  |  |  |  |  |  |  |
| 13447005 |  | 45 MeV Dump - Remove | 8d | 2012-05-18 A | 2012-05-30 A | 13444018, 2-02M FS+14d | 100% |  |  |  | MECH TECH [104 h]; MECH ENG [76 h] | 9,950.88 | 9,950.88 |  |  | 0 | 9950.88 | BEVINS M | 1 | 1 | H | MIKE B |  |  | 12-035 |  |  |  |  | 10-065 |  |  |  | 13447005 |  |  |  |  |  |  |  |  |  |
| 13447015 |  | OL/OR - Remove | 26d | 2012-06-11 A | 2012-07-16 A | 13417050M FS-50d | 100% |  |  |  | MECH TECH [360 h]; MECH ENG [260 h] | 34,229.6 | 34,229.6 |  |  | 0 | 34229.6 | BEVINS M | 1 | 1 | H | MIKE B |  |  | 12-035 |  |  |  |  | 10-065 |  |  |  | 13447015 |  |  |  |  |  |  |  |  |  |
| 13447025 |  | OL/OR - Upstairs | 119d | 2012-07-09 A | 2013-05-13 A | 13447015 FS-5d | 100% | 2012-07-09 | 2013-01-02 |  | MECH TECH [192 h]; MECH ENG [140 h] | 18,644.87 | 18,770.81 |  |  | 0 | 18349.28 | BEVINS M | 1 | 1 | H | MIKE B |  |  | 12-035 |  |  |  |  | 10-065 |  |  |  |  | XX |  |  |  |  |  |  |  |  |
| 13447020 |  | OL/OR - Install stands FY12 | 49.58d | 2012-08-06 A | 2012-10-15 A | 13447015 | 100% |  |  |  | MECH TECH [180 h]; MECH ENG [86 h] | 14,125.17 | 14,125.17 |  |  | 0 | 14029.52 | BEVINS M | 1 | 1 | H | MIKE B |  |  | 12-035 |  |  |  |  | 10-065 |  |  |  | 13447020 |  | OPC A | 12-053 |  |  |  |  |  |  |
| 13447020a |  | OL/OR - Install stands FY13 | 50d | 2012-08-06 A | 2012-10-15 A | 13447020 FS-20d | 100% |  |  |  | MECH TECH [180 h]; MECH ENG [86 h] | 14,128.13 | 14,128.13 |  |  | 0 | 14477.76 | BEVINS M | 1 | 1 | H | MIKE B |  |  | 12-035 |  |  |  |  | 10-065 |  |  |  | 13447020 |  |  | 12-053 |  |  |  |  |  |  |
| 13447030 |  | OL/OR - Install magnets and girders | 84d | 2012-09-10 A | 2013-06-17 A | 13447020 FS-10d, 13447020a FS-10d, 13447025 FS-20d | 100% | 2012-09-10 | 2013-01-15 |  | MECH TECH [664 h]; MECH ENG [148 h] | 40,932.75 | 41,059.71 |  |  | 0 | 41160.32 | BEVINS M | 1 | 1 | H | MIKE B |  |  | 12-035 |  |  |  |  | 10-065 |  |  |  |  | XX | OPC A |  |  |  |  |  |  |  |
| 13447035 |  | OL/OR - Final align | 10d | 2012-12-10 A | 2013-07-15 A | 13447030 FS-25d | 100% | 2013-02-08 | 2013-02-22 |  | MECH TECH [200 h]; MECH ENG [44 h] | 12,355.84 | 12,355.84 |  |  | 0 | 12355.84 | BEVINS M | 1 | 1 | H | MIKE B |  |  | 12-035 |  |  |  |  | 10-065 |  |  |  | 13447035 | XX | OPC A |  |  |  |  |  |  |  |
| 13447010 |  | 45 MeV Dump - Re-install | 6d | 2013-08-30 A | 2013-08-30 A | 13447005 FS+280d | 100% | 2013-09-03 | 2013-09-10 |  | MECH TECH [104 h]; MECH ENG [24 h] | 6,506.08 | 6,506.08 |  |  | 6506.08 | 6506.08 | BEVINS M | 1 | 1 | H | MIKE B |  |  | 12-035 |  |  |  |  | 10-065 |  |  |  | 13447010 |  | OPC A |  |  |  |  |  |  |  |
| 13447040 |  | Re-Baseline Actuals Adjustment | 1d | 2013-08-30 A | 2013-08-30 A |  | 100% | 2013-09-03 | 2013-09-03 |  | PROCUREMENT>$50K 69 NO ESCALATION | -5,188.41 |  |  |  |  |  |  |  |  |  |  |  |  |  |  |  |  | 100 |  |  | ADJ |  |  |  |  |  |  |  |  |  |  |  |
| 23447010 |  | 45 MeV Dump - Re-install | 11d | 2013-09-03 A | 2013-10-21 A | 9-130M FS+228d | 100% | 2013-10-01 | 2013-10-15 | 8/5 M-F w/JLAB Holidays ReBaseline | MECH TECH [256 h]; MECH ENG [64 h] | 16,892.8 | 16,699.61 |  |  |  | 1637.12 | BEVINS M | 1 | 1 | S | MIKE B |  |  | 12-035 |  |  |  |  | 10-065 |  |  |  |  |  |  |  | 23447010 | 14734.08 | ST | PE | 13-015 | PR |

Notes:
- 23447010: Steps: Install dump (done); Align for hookup (done); Vacuum hookup (done); Final align (done); Install shielding (done)

| ID | WBS | Activity | Type | Duration | Start | Finish | Predecessors | Complete | Planned start | Planned finish | Resources | Cost | Actual cost | LOE Divider | LOE Multiplier | Calculated Remaining Total Cost | MONTHLY EV COST | RESP - Responsibility | STRT%COMP for CM EVM | FNSH%COMP for CM EVM | EVMS Reporting Codes | CAM RESPONSIBLE | CR 08-058 | CR 08-029 | CR 10-065 | Milestone Level | CR 09-033 | CR 09-033 Repair | Remaining Material Cost Based on % Compl | Claimed Material Cost Based on % Complet | Initial Claimed Material Calc | Claimed Material Divider | Advance Purchase Plan > 500K | CR 08-016 | 12 GEV MAJOR PROCUREMENT CATAGORY | CR 10-001 | CR 09-012 | CR 10-003 | CR 11-001 | Inter Project Link (IPL) | CR 10-030 | CR 12-001 | LOE % Pre Calc | LOE % | Profile change | ReBaseline Actuals Adjustment |
| --- | --- | --- | --- | --- | --- | --- | --- | --- | --- | --- | --- | --- | --- | --- | --- | --- | --- | --- | --- | --- | --- | --- | --- | --- | --- | --- | --- | --- | --- | --- | --- | --- | --- | --- | --- | --- | --- | --- | --- | --- | --- | --- | --- | --- | --- | --- |
|  | 5 | **1.3.4.5 ARC 10 & HALL D BEAMLINE** |  |  | 2009-01-02 | 2013-12-03 |  |  |  |  |  |  |  |  |  |  |  |  |  |  |  |  |  |  |  |  |  |  |  |  |  |  |  |  |  |  |  |  |  |  |  |  |  |  |  |  |
|  | 1 | **1.3.4.5.1 DIPOLES** |  |  | 2009-01-02 | 2013-08-30 |  |  |  |  |  |  |  |  |  |  |  |  |  |  |  |  |  |  |  |  |  |  |  |  |  |  |  |  |  |  |  |  |  |  |  |  |  |  |  |  |
| 13451909LOE |  | FY09 Mngmnt & Oversight (ARC10/H-D Dipoles) |  | 189d | 2009-01-02 A | 2009-09-30 A | 13451909LOEXD | 100% |  |  | SR STAFF [152.42 h]; TRAVEL | 21,079.42 | 15,674.87 | 100 | 100 | 0 | 21079.418093 | BEVINS M | 1 | 1 | E | MIKE B | 08-058 |  |  |  |  |  |  |  |  |  |  |  |  |  |  |  |  |  |  |  |  |  |  |  |
| 13451055 |  | Prcrmnt Prep of 4m Dipoles (ARC10/H-D Dipoles) |  | 98d | 2009-01-05 A | 2009-05-25 A | 13451055XD | 100% | 2009-01-05 | 2009-05-22 | MECH ENG [5.09 h]; MECH DES [3.39 h] | 473.41 | 473.41 |  |  | 0 | 473.4105 | BEVINS M | 1 | 1 | H | MIKE B | 08-058 | 08-029 |  |  |  |  |  |  |  |  |  |  |  |  |  |  |  |  |  |  |  |  |  |  |
| 13451075 |  | Prcrmnt Prep for 2m Pass 6 Dipole (ARC10/H-D Dipoles) |  | 188d | 2009-03-02 A | 2009-11-23 A | 121451035, 9-090M FS+65d, 121456999 FS-15d | 100% |  |  | MECH DES [36 h]; MECH ENG [40 h] | 4,157.32 | 4,157.32 |  |  | 0 | 4130.64 | BEVINS M | 1 | 1 | H | MIKE B |  | 08-029 | 10-065 |  |  |  |  |  |  |  |  |  |  |  |  |  |  |  |  |  |  |  |  |  |
| 13451060M |  | Award Contract for 4m Dipl (ARC10/H-D Dipl) | milestone | 0d | 2009-06-02 A | 2009-06-02 A | 13451055 | 100% | 2009-07-01 | 2009-07-01 |  |  |  |  |  |  | 0 | BEVINS M | 1 | 1 | M | MIKE B |  | 08-029 |  | 6 | 09-033 | 09-033 |  |  |  |  |  |  |  |  |  |  |  |  |  |  |  |  |  |  |
| 13451063a |  | PROC 4m Dpl Cntr PP3a for Coil Material (ARC10/H-D Dipl) |  | 38d | 2009-07-01 A | 2009-08-24 A | 13451060M FS+21d | 100% |  |  | PROCUREMENT<$50K 60; PROCUREMENT>$50K 69 | 168,436 |  |  |  | 0 | 168436 | BEVINS M | 1 | 1 | D | MIKE B |  | 08-029 | 10-065 |  | 09-033 | 09-033 | 0 | 168436 | 16843600 | 100 | APP | 08-016 | 3451 |  |  |  |  |  |  |  |  |  |  |  |
| 13451063b |  | PROC 4m Dpl Cntr PP3b for Core Material (ARC10/H-D Dipl) |  | 58d | 2009-07-01 A | 2009-09-22 A | 13451063a FS-65d | 100% |  |  | PROCUREMENT<$50K 60; PROCUREMENT>$50K 69 | 615,565 |  |  |  | 0 | 615565 | BEVINS M | 1 | 1 | D | MIKE B |  | 08-029 | 10-065 |  | 09-033 | 09-033 | 0 | 615565 | 61556500 | 100 | APP | 08-016 | 3451 |  |  |  |  |  |  |  |  |  |  |  |
| 13451063c |  | PROC 4m Dipl Cntr PP3c for 1st Article Coil Set (ARC10/H-D Dipl) |  | 159d | 2009-07-01 A | 2010-02-24 A | 13451063b FS-21d | 100% |  |  | PROCUREMENT<$50K 60 NO ESCALATION; PROCUREMENT>$50K 69 NO ESCALATION | 3,856 |  |  |  | 0 | 3856 | BEVINS M | 1 | 1 | D | MIKE B |  | 08-029 | 10-065 |  | 09-033 | 09-033 | 0 | 3856 | 385600 | 100 | APP | 08-016 | 3451 | 10-001A |  |  |  |  |  |  |  |  |  |  |
| 13451063d |  | PROC 4m Dipl Cntr PP3d for 1st Article Core Set (ARC10/H-D Dipl) |  | 159d | 2009-07-01 A | 2010-02-24 A | 13451063c FS-62d, 13451060M FS+21d | 100% |  |  | PROCUREMENT>$50K 69 NO ESCALATION; PROCUREMENT<$50K 60 NO ESCALATION | 23,537 |  |  |  | 0 | 23537 | BEVINS M | 1 | 1 | D | MIKE B |  | 08-029 | 10-065 |  | 09-033 | 09-033 | 0 | 23537 | 2353700 | 100 | APP | 08-016 | 3451 | 10-001A |  |  |  |  |  |  |  |  |  |  |
| 13451063e-1 |  | PROC 4m Dipl Cntr PP3e-1 Deliver 6 Magnets (ARC10/H-D Dipl) |  | 222d | 2009-07-01 A | 2010-05-24 A | 13451063d FS-80d | 100% |  |  | PROCUREMENT>$50K 69 NO ESCALATION; PROCUREMENT<$50K 60 NO ESCALATION | 164,358 |  | 100 | 100 | 0 | 164358 | BEVINS M | 1 | 1 | D | MIKE B |  | 08-029 | 10-065 |  | 09-033 | 09-033 | 0 | 164358 | 16435800 | 100 | APP | 08-016 | 3451 | 10-001A |  |  |  |  |  |  |  |  |  |  |
| 13451063e-2 |  | PROC 4m Dipl Cntr PP3e-2 Deliver 10 Magnets (ARC10/H-D Dipl) |  | 285d | 2009-07-01 A | 2010-08-23 A | 13451063e-1 FS-118d | 100% |  |  | PROCUREMENT>$50K 69 NO ESCALATION; PROCUREMENT<$50K 60 NO ESCALATION | 273,930 |  | 100 | 100 | 0 | 273930 | BEVINS M | 1 | 1 | D | MIKE B |  | 08-029 | 10-065 |  | 09-033 | 09-033 | 0 | 273930 | 27393000 | 100 | APP | 08-016 | 3451 | 10-001A |  |  |  |  |  |  |  |  |  |  |
| 13451063e-3 |  | PROC 4m Dipl Cntr PP3e-3 Deliver 10 Magnets (ARC10/H-D Dipl) |  | 344d | 2009-07-01 A | 2010-11-15 A | 13451063e-2 FS-163d | 100% |  |  | PROCUREMENT>$50K 69 NO ESCALATION; PROCUREMENT<$50K 60 NO ESCALATION | 273,930 |  | 100 | 100 | 0 | 273930 | BEVINS M | 1 | 1 | D | MIKE B |  | 08-029 | 10-065 |  | 09-033 | 09-033 | 0 | 273930 | 27393000 | 100 | APP | 08-016 | 3451 | 10-001A |  |  |  |  |  |  |  |  |  |  |
| 13451063e-4 |  | PROC 4m Dipl Cntr PP3e-4 Deliver 10 Magnets (ARC10/H-D Dipl) |  | 385d | 2009-07-01 A | 2011-01-24 A | 13451063e-3 FS-205d | 100% |  |  | PROCUREMENT>$50K 69 NO ESCALATION; PROCUREMENT<$50K 60 NO ESCALATION | 273,930 |  | 100 | 100 | 0 | 273930 | BEVINS M | 1 | 1 | D | MIKE B |  | 08-029 | 10-065 |  | 09-033 | 09-033 | 0 | 273930 | 27393000 | 100 | APP | 08-016 | 3451 | 10-001A |  |  |  |  |  |  |  |  |  |  |
| 13451065 |  | FY09 LABOR Oversight 4m Dipl Contract (ARC10/H-D Dipl) |  | 64d | 2009-07-01 A | 2009-09-30 A | 13451060M | 100% |  |  | MECH ENG [114.48 h]; MECH DES [41.1 h] | 9,106.79 | 9,106.79 |  |  | 0 | 9106.860873 | BEVINS M | 1 | 1 | H | MIKE B |  | 08-029 | 10-065 |  | 09-033 | 09-033 |  |  |  |  | APP | 08-016 | 3451 |  | 09-012 |  |  |  |  |  |  |  |  |  |
| 13451066 |  | FY 10 LABOR Oversight 4m Dipl Contract (ARC10/H-D Dipl) |  | 227d | 2009-10-01 A | 2010-08-31 A | 13451065 | 100% |  |  | MECH ENG [181.52 h]; MECH DES [54.9 h] | 14,436.77 | 14,436.77 | 100 | 100 | 0 | 14436.698008 | BEVINS M | 1 | 1 | E | MIKE B |  | 08-029 | 10-065 |  | 09-033 | 09-033 |  |  |  |  | APP | 08-016 | 3451 |  | 09-012 |  |  |  |  |  |  |  |  |  |
| 13451910LOE |  | FY10 Mngmnt & Oversight (ARC10/H-D Dipoles) |  | 248d | 2009-10-01 A | 2010-09-30 A | 121451909LOE, 13451909LOE | 100% |  |  | TRAVEL; SR STAFF [200 h] | 34,035.83 | 21,224 | 100 | 100 | 0 | 34035.833063 | BEVINS M | 1 | 1 | E | MIKE B |  |  |  |  |  |  |  |  |  |  |  |  |  |  |  |  |  |  |  |  |  |  |  |  |
| 13451085 |  | P-1 Vend Fab 2m Pass 6 Dipole (ARC10/H-D Dipoles) Labor FY09 |  | 63d | 2009-11-18 A | 2010-02-26 A | 13451080M | 100% |  |  | MECH ENG [27.68 h]; MECH DES [11.71 h] | 2,352.49 | 2,352.49 |  |  | 0 | 2279.6272 | BEVINS M | 1 | 1 | H | MIKE B |  | 08-029 | 10-065 |  |  |  |  |  |  |  | APP | 08-016 |  | 10-001B | 09-012 |  |  |  |  |  |  |  |  |  |
| 13451085b |  | P-1 Vend Fab 2m Pass 6 Dipole (ARC10/H-D Dipoles) Labor FY10 |  | 63d | 2009-11-18 A | 2010-02-26 A | 13451085 FS-250d | 100% |  |  | MECH ENG [76.32 h]; MECH DES [32.29 h] | 6,486.47 | 6,486.47 |  |  | 0 | 6486.4716 | BEVINS M | 1 | 1 | H | MIKE B |  |  | 10-065 |  |  |  |  |  |  |  | APP |  |  | 10-001B |  |  |  |  |  |  |  |  |  |  |
| 13451080M |  | Award Contract for 2m Pass 6 Dipole (ARC10/H-D DIPOLES) | milestone | 0d | 2009-11-23 A | 2009-11-23 A | 13451075 | 100% | 2010-01-04 | 2010-01-04 |  |  |  |  |  |  | 0 | BEVINS M | 1 | 1 | M | MIKE B |  | 08-029 | 10-065 | 6 |  |  |  |  |  |  |  |  |  |  |  |  |  |  |  |  |  |  |  |  |
| 13451086 |  | P-2 Vend Fab 2m Pass 6 Dipole (ARC10/H-D Dipoles) Original Labor FY10 |  | 248d | 2010-01-29 A | 2011-01-28 A | 13451085b FS-125d | 100% |  |  | MECH ENG [68.95 h]; MECH DES [30.34 h] | 5,971.46 | 5,971.46 | 100 | 100 | 0 | 5912.9391 | BEVINS M | 1 | 1 | E | MIKE B |  | 08-029 | 10-065 |  |  |  |  |  |  |  | APP | 08-016 |  |  | 09-012 | 10-003 | 11-001 |  |  |  |  |  |  |  |
| 13451086a |  | P-2 Vend Fab 2m Pass 6 Dipole (ARC10/H-D Dipoles) Original Labor FY11 |  | 248d | 2010-01-29 A | 2011-01-28 A | 13451085b FS-125d | 100% |  |  | MECH ENG [31.05 h]; MECH DES [13.66 h] | 2,688.98 | 2,688.98 | 100 | 100 | 0 | 2747.4963 | BEVINS M | 1 | 1 | E | MIKE B |  | 08-029 | 10-065 |  |  |  |  |  |  |  | APP | 08-016 |  |  | 09-012 | 10-003 | 11-001 |  |  |  |  |  |  |  |
| 13451068M |  | Deliver 1st Article 4m Dipl (ARC10/H-D Dipl) (IPL) | milestone | 0d | 2010-02-24 A | 2010-02-24 A | 13451063a, 13451063d | 100% | 2010-03-24 | 2010-03-24 |  |  |  |  |  |  | 0 | BEVINS M | 1 | 1 | M | MIKE B |  | 08-029 | 10-065 | 6 | 09-033 | 09-033 |  |  |  |  |  |  |  |  |  |  |  | IPL |  |  |  |  |  |  |
| 13451100 |  | Mag Measurement of Arc 10 & H-D Dipoles (ARC10/H-D Dipoles) FY10 |  | 16d | 2010-07-02 A | 2010-07-26 A | 13451070M FS-295d, 13451090M FS-404d, 121421022 FS-100d | 100% |  |  | OFFICE [8 h]; MECH ENG [192 h]; MECH TECH [320 h]; COMP SCIENT [8 h] | 26,707.44 | 26,707.44 |  |  | 0 | 26707.44 | BEVINS M | 1 | 1 | U | MIKE B |  | 08-029 | 10-065 |  |  |  |  |  |  |  |  |  |  |  |  | 10-003 | 11-001 |  | 10-030 |  |  |  |  |  |
| 13451100a |  | Mag Measurement of Arc 10 & H-D Dipoles (ARC10/H-D Dipoles) FY11 |  | 16d | 2010-07-02 A | 2010-07-26 A | 121421022 FS-100d, 13451070M FS-295d, 13451090M FS-404d | 100% |  |  | MECH ENG [288 h]; MECH TECH [480 h]; COMP SCIENT [12 h]; OFFICE [12 h] | 40,061.16 | 40,061.16 |  |  | 0 | 41338.32 | BEVINS M | 1 | 1 | U | MIKE B |  | 08-029 | 10-065 |  |  |  |  |  |  |  |  |  |  |  |  | 10-003 | 11-001 |  | 10-030 |  |  |  |  |  |
| 13451105 |  | Completion of Mag Measurement of Arc 10 & H-D Dipl (ARC10/H-D Dipl) FY11 |  | 151d | 2010-09-13 A | 2011-04-25 A | 13451100 FS-50d, 13451100a FS-50d | 100% |  |  | MECH TECH [430.77 h]; MECH ENG [163.69 h] | 29,591.01 | 29,591.01 |  |  | 0 | 29675.9994 | BEVINS M | 1 | 1 | U | MIKE B |  |  | 10-065 |  |  |  |  |  |  |  |  |  |  |  |  |  |  |  |  | 12-001 |  |  |  |  |
| 13451105a |  | Completion of Mag Measurement of Arc 10 & H-D Dipl (ARC10/H-D Dipl) FY12 |  | 151d | 2010-09-13 A | 2011-04-25 A | 13451105 | 100% |  |  | MECH TECH [1569.23 h]; MECH ENG [596.31 h] | 107,796.39 | 107,796.39 |  |  | 0 | 111549.8384 | BEVINS M | 1 | 1 | U | MIKE B |  |  | 10-065 |  |  |  |  |  |  |  |  |  |  |  |  |  |  |  |  | 12-001 |  |  |  |  |
| 13451911LOE |  | FY11 Mngmnt & Oversight (ARC10/H-D Dipoles) |  | 248d | 2010-10-01 A | 2011-09-30 A | 13451910LOE | 100% |  |  | SR STAFF [200 h] | 21,902 | 21,902 | 100 | 100 | 0 | 21902 | BEVINS M | 1 | 1 | E | MIKE B |  |  |  |  |  |  |  |  |  |  |  |  |  |  |  |  |  |  |  |  | 8.46774193 | 91.53225806 |  |  |
| 13451070M |  | Delivery Complete for all 4m Dipl (ARC10/H-D Dipl) | milestone | 0d | 2011-01-24 A | 2011-01-24 A | 13451063e-4, 13451068M, 13451063e-4 FF, 13451066 | 100% | 2011-02-22 | 2011-02-22 |  |  |  |  |  |  | 0 | BEVINS M | 1 | 1 | M | MIKE B |  | 08-029 | 10-065 | 6 | 09-033 | 09-033 |  |  |  |  |  |  |  |  |  |  |  |  |  |  |  |  |  |  |
| 13451090M |  | Delivery Complete for 2m Pass 6 Dipole (ARC10/H-D Dipl) | milestone | 0d | 2011-01-24 A | 2011-01-24 A | 13451086, 13451086a | 100% | 2011-11-17 | 2011-11-17 |  |  |  |  |  |  | 0 | BEVINS M | 1 | 1 | M | MIKE B |  | 08-029 | 10-065 | 6 |  |  |  |  |  |  |  |  |  |  |  | 10-003 |  |  |  |  |  |  |  |  |
| 13451095 |  | Modify Alignment Fixture for Dipoles (ARC10/H-D Dipoles) |  | 40d | 2011-03-01 A | 2011-04-25 A | 9-110M FS+120d | 100% |  |  | PROCUREMENT<$50K 60; MECH TECH [8 h] | 12,321.32 | 344.56 |  |  | 0 | 12321.32 | BEVINS M | 1 | 1 | H | MIKE B |  | 08-029 |  |  |  |  | 0 | 11976.76 | 1197676 | 100 | APP |  |  |  |  |  |  |  |  |  |  |  | C |  |
| 13451912LOE |  | FY12 Mngmnt & Oversight (ARC10/H-D Dipoles) |  | 15d | 2011-09-03 A | 2011-09-26 A | 13451911LOE | 100% | 2011-09-06 | 2011-09-26 | SR STAFF [200 h] | 21,902 | 21,902 | 100 | 100 | 0 | 22600 | BEVINS M | 1 | 1 | H | MIKE B |  |  |  |  |  |  |  |  |  |  |  |  |  |  |  |  |  |  |  |  | 100 | 0 |  |  |
| 13451950 |  | Re-Baseline Actuals Adjustment |  | 1d | 2013-08-30 A | 2013-08-30 A |  | 100% | 2013-09-03 | 2013-09-03 | PROCUREMENT>$50K 69 NO ESCALATION | 206,225.01 |  |  |  |  | 206225.01 |  |  |  |  |  |  |  |  |  |  |  | 0 | 206225.01 | 20622501 | 100 |  |  |  |  |  |  |  |  |  |  |  |  |  | ADJ |

| ID | WBS | Activity | Type | Duration | Start | Finish | Predecessors | Complete | Planned start | Planned finish | Resources | Cost | Actual cost | Calculated Remaining Total Cost | MONTHLY EV COST | RESP - Responsibility | STRT%COMP for CM EVM | FNSH%COMP for CM EVM | EVMS Reporting Codes | CAM RESPONSIBLE | CR 08-029 | CR 08-058 | Milestone Level | CR 09-040 | CR 09-012 | CR 10-001 | CR 11-026 | CR 12-018 | Advance Purchase Plan > 500K | CR 08-016 | CR 08-051 | 12 GEV MAJOR PROCUREMENT CATAGORY | Remaining Material Cost Based on % Compl | Claimed Material Cost Based on % Complet | Initial Claimed Material Calc | Claimed Material Divider | LOE Divider | LOE Multiplier | CR 10-030 | CR 11-001 | Inter Project Link (IPL) | CR 08-052 | Activities with Steps | CR 10-065 | ReBaseline Actuals Adjustment |
| --- | --- | --- | --- | --- | --- | --- | --- | --- | --- | --- | --- | --- | --- | --- | --- | --- | --- | --- | --- | --- | --- | --- | --- | --- | --- | --- | --- | --- | --- | --- | --- | --- | --- | --- | --- | --- | --- | --- | --- | --- | --- | --- | --- | --- | --- |
|  | 2 | **1.3.4.5.2 QUADRUPOLES** |  |  | 2009-01-05 | 2013-08-30 |  |  |  |  |  |  |  |  |  |  |  |  |  |  |  |  |  |  |  |  |  |  |  |  |  |  |  |  |  |  |  |  |  |  |  |  |  |  |  |
| 13452025 |  | Prcrmnt Prep for Quads (ARC 10/H-D Q-POLES) |  | 124d | 2009-01-05 A | 2009-06-30 A | 13452025X | 100% |  |  | MECH DES [28.13 h]; MECH ENG [28.13 h] | 3,028.2 | 3,028.2 | 0 | 3028.1945 | BEVINS M | 1 | 1 | H | MIKE B | 08-029 | 08-058 |  |  |  |  |  |  |  |  |  |  |  |  |  |  |  |  |  |  |  |  |  |  |  |
| 13452030M |  | Award Contract for Quadrupoles (ARC 10/H-D Q-POLES) | milestone | 0d | 2009-07-01 A | 2009-07-01 A | 13452025X, 13452025, 9-090M FS+206d, 1114010 | 100% | 2009-08-03 | 2009-08-03 |  |  |  |  | 0 | BEVINS M | 1 | 1 | M | MIKE B | 08-029 |  | 6 | 09-040 |  |  |  |  |  |  |  |  |  |  |  |  |  |  |  |  |  |  |  |  |  |
| 13453010 |  | Prcrmnt Prep for Correctors (ARC10/H-D Correctors) FY09 |  | 109d | 2009-07-16 A | 2009-12-21 A | 9-090M FS+185d | 100% | 2009-07-16 | 2009-12-18 | MECH ENG [21.72 h]; MECH DES [21.72 h] | 2,375.86 | 2,375.86 | 0 | 2338.158 | BEVINS M | 1 | 1 | H | MIKE B | 08-029 |  |  |  | 09-012 | 10-001B | 11-026 | 12-018F |  |  |  |  |  |  |  |  |  |  |  |  |  |  |  |  |  |
| 13452035 |  | Vend Fab Quads (ARC 10/H-D Q-POLES) LABOR Initial |  | 42d | 2009-08-03 A | 2009-09-30 A | 9-090M FS+91d | 100% |  |  | MECH ENG [64.92 h]; MECH DES [74.2 h] | 7,395.53 | 7,395.53 | 0 | 7395.52646 | BEVINS M | 1 | 1 | H | MIKE B | 08-029 |  |  | 09-040 | 09-012 |  | 11-026 | 12-018F | APP | 08-016 | 08-051 | 3422 |  |  |  |  |  |  |  |  |  |  |  |  |  |
| 13452037 |  | Vend Fab Quads (ARC 10/H-D Q-POLES) Recieve Materials |  | 64d | 2009-08-03 A | 2009-10-30 A | 13452035 FS-115d | 100% |  |  | PROCUREMENT<$50K 60 NO ESCALATION; PROCUREMENT>$50K 69 NO ESCALATION | 80,850 |  | 0 | 80850 | BEVINS M | 1 | 1 | P | MIKE B | 08-029 |  |  | 09-040 |  | 10-001A | 11-026 | 12-018F | APP | 08-016 |  | 3422 | 0 | 80850 | 8085000 | 100 |  |  |  |  |  |  |  |  |  |
| 13452037A |  | Vend Fab Quads (ARC 10/H-D Q-POLES) Lamination Stampings |  | 97d | 2009-08-03 A | 2009-12-21 A | 13452037 FS-24d, 13452035 FS-115d | 100% | 2009-08-03 | 2009-12-18 | PROCUREMENT>$50K 69 | 18,375 |  | 0 | 18375 | BEVINS M | 1 | 1 | P | MIKE B | 08-029 |  |  | 09-040 |  |  | 11-026 | 12-018F | APP | 08-016 |  | 3422 | 0 | 18375 | 1837500 | 100 |  |  |  |  |  |  |  |  |  |
| 13452037B |  | Vend Fab Quads (ARC 10/H-D Q-POLES) First Article QP |  | 83d | 2009-08-03 A | 2009-11-30 A | 13452037A FS-1d | 100% |  |  | PROCUREMENT>$50K 69 NO ESCALATION | 19,500 |  | 0 | 19500 | BEVINS M | 1 | 1 | P | MIKE B | 08-029 |  |  | 09-040 |  | 10-001A | 11-026 | 12-018F | APP | 08-016 |  | 3422 | 0 | 19500 | 1950000 | 100 |  |  |  |  |  |  |  |  |  |
| 13452037C |  | Vend Fab Quads (ARC 10/H-D Q-POLES) Deliver 8 QP Magnets |  | 116d | 2009-08-03 A | 2010-01-25 A | 13452037B FS-33d | 100% |  |  | PROCUREMENT>$50K 69 NO ESCALATION | 56,000 |  | 0 | 56000 | BEVINS M | 1 | 1 | P | MIKE B | 08-029 |  |  | 09-040 |  | 10-001A | 11-026 | 12-018F | APP | 08-016 |  | 3422 | 0 | 56000 | 5600000 | 100 |  |  |  |  |  |  |  |  |  |
| 13452037D |  | Vend Fab Quads (ARC 10/H-D Q-POLES) Deliver 8 QP Magnets |  | 160d | 2009-08-03 A | 2010-03-29 A | 13452037C FS-80d | 100% |  |  | PROCUREMENT>$50K 69 NO ESCALATION | 56,000 |  | 0 | 56000 | BEVINS M | 1 | 1 | D | MIKE B | 08-029 |  |  | 09-040 |  | 10-001A | 11-026 | 12-018F | APP | 08-016 |  | 3422 | 0 | 56000 | 5600000 | 100 |  |  |  |  |  |  |  |  |  |
| 13452037F |  | Vend Fab Quads (ARC 10/H-D Q-POLES) Deliver 3 QR Magnets |  | 116d | 2009-08-03 A | 2010-01-25 A | 13452037D FS-99d | 100% |  |  | PROCUREMENT>$50K 69 NO ESCALATION | 23,100 |  | 0 | 23100 | BEVINS M | 1 | 1 | P | MIKE B | 08-029 |  |  | 09-040 |  | 10-001A | 11-026 | 12-018F | APP | 08-016 |  | 3422 | 0 | 23100 | 2310000 | 100 |  |  |  |  |  |  |  |  |  |
| 13452037G |  | Vend Fab Quads (ARC 10/H-D Q-POLES) Deliver 8 QP Magnets |  | 181d | 2009-08-03 A | 2010-04-27 A | 13452037F FS-99d | 100% |  |  | PROCUREMENT>$50K 69 NO ESCALATION | 56,000 |  | 0 | 56000 | BEVINS M | 1 | 1 | D | MIKE B | 08-029 |  |  | 09-040 |  | 10-001A | 11-026 | 12-018F | APP | 08-016 |  | 3422 | 0 | 56000 | 5600000 | 100 |  |  |  |  |  |  |  |  |  |
| 13452037H |  | Vend Fab Quads (ARC 10/H-D Q-POLES) Deliver 3 QR Magnets |  | 138d | 2009-08-03 A | 2010-02-25 A | 13452037G FS-118d | 100% |  |  | PROCUREMENT>$50K 69 NO ESCALATION | 23,100 |  | 0 | 23100 | BEVINS M | 1 | 1 | P | MIKE B | 08-029 |  |  | 09-040 |  | 10-001A | 11-026 | 12-018F | APP | 08-016 |  | 3422 | 0 | 23100 | 2310000 | 100 |  |  |  |  |  |  |  |  |  |
| 13452037J |  | Vend Fab Quads (ARC 10/H-D Q-POLES) Deliver 8 QP Magnets |  | 200d | 2009-08-03 A | 2010-05-24 A | 13452037H FS-118d | 100% |  |  | PROCUREMENT>$50K 69 NO ESCALATION | 56,000 |  | 0 | 56000 | BEVINS M | 1 | 1 | D | MIKE B | 08-029 |  |  | 09-040 |  | 10-001A | 11-026 | 12-018F | APP | 08-016 |  | 3422 | 0 | 56000 | 5600000 | 100 |  |  |  |  |  |  |  |  |  |
| 13452037K |  | Vend Fab Quads (ARC 10/H-D Q-POLES) Deliver 3 QR Magnets |  | 200d | 2009-08-03 A | 2010-05-24 A | 13452037J FS-139d | 100% |  |  | PROCUREMENT>$50K 69 NO ESCALATION | 23,100 |  | 0 | 23100 | BEVINS M | 1 | 1 | D | MIKE B | 08-029 |  |  | 09-040 |  | 10-001A | 11-026 | 12-018F | APP | 08-016 |  | 3422 | 0 | 23100 | 2310000 | 100 |  |  |  |  |  |  |  |  |  |
| 13452037L |  | Vend Fab Quads (ARC 10/H-D Q-POLES) Deliver 8 QP Magnets |  | 226d | 2009-08-03 A | 2010-06-30 A | 13452037K FS-139d | 100% |  |  | PROCUREMENT>$50K 69 NO ESCALATION | 56,000 |  | 0 | 56000 | BEVINS M | 1 | 1 | D | MIKE B | 08-029 |  |  | 09-040 |  | 10-001A | 11-026 | 12-018F | APP | 08-016 |  | 3422 | 0 | 56000 | 5600000 | 100 |  |  |  |  |  |  |  |  |  |
| 13452037N |  | Vend Fab Quads (ARC 10/H-D Q-POLES) Deliver 3 QR Magnets |  | 200d | 2009-08-03 A | 2010-05-24 A | 13452037L FS-163d | 100% |  |  | PROCUREMENT>$50K 69 NO ESCALATION | 23,100 |  | 0 | 23100 | BEVINS M | 1 | 1 | D | MIKE B | 08-029 |  |  | 09-040 |  | 10-001A | 11-026 | 12-018F | APP | 08-016 |  | 3422 | 0 | 23100 | 2310000 | 100 |  |  |  |  |  |  |  |  |  |
| 13452037P |  | Vend Fab Quads (ARC 10/H-D Q-POLES) Deliver 3 QR Magnets |  | 226d | 2009-08-03 A | 2010-06-30 A | 13452037o FS-183d | 100% |  |  | PROCUREMENT>$50K 69 NO ESCALATION | 23,100 |  | 0 | 23100 | BEVINS M | 1 | 1 | D | MIKE B | 08-029 |  |  | 09-040 |  | 10-001A | 11-026 | 12-018F | APP | 08-016 |  | 3422 | 0 | 23100 | 2310000 | 100 |  |  |  |  |  |  |  |  |  |
| 13452037Q |  | Vend Fab Quads (ARC 10/H-D Q-POLES) Deliver 4 QP Magnets |  | 243d | 2009-08-03 A | 2010-07-26 A | 13452037P FS-183d | 100% |  |  | PROCUREMENT>$50K 69 NO ESCALATION | 28,000 |  | 0 | 28000 | BEVINS M | 1 | 1 | D | MIKE B | 08-029 |  |  | 09-040 |  | 10-001A | 11-026 | 12-018F | APP | 08-016 |  | 3422 | 0 | 28000 | 2800000 | 100 |  |  |  |  |  |  |  |  |  |
| 13452037R |  | Vend Fab Quads (ARC 10/H-D Q-POLES) Deliver 3 QR Magnets |  | 226d | 2009-08-03 A | 2010-06-30 A | 13452037Q FS-200d | 100% |  |  | PROCUREMENT>$50K 69 NO ESCALATION | 23,100 |  | 0 | 23100 | BEVINS M | 1 | 1 | D | MIKE B | 08-029 |  |  | 09-040 |  | 10-001A | 11-026 | 12-018F | APP | 08-016 |  | 3422 | 0 | 23100 | 2310000 | 100 |  |  |  |  |  |  |  |  |  |
| 13452037S |  | Vend Fab Quads (ARC 10/H-D Q-POLES) Deliver 2 QR Magnets |  | 226d | 2009-08-03 A | 2010-06-30 A | 13452037R FS-200d | 100% |  |  | PROCUREMENT>$50K 69 NO ESCALATION | 15,400 |  | 0 | 15400 | BEVINS M | 1 | 1 | D | MIKE B | 08-029 |  |  | 09-040 |  | 10-001A | 11-026 | 12-018F | APP | 08-016 |  | 3422 | 0 | 15400 | 1540000 | 100 |  |  |  |  |  |  |  |  |  |
| 13452037T |  | Vend Fab Quads (ARC 10/H-D Q-POLES) Deliver 4 QP Magnets |  | 243d | 2009-08-03 A | 2010-07-26 A | 13452037S FS-222d | 100% |  |  | PROCUREMENT<$50K 60 NO ESCALATION | 38,400 |  | 0 | 38400 | BEVINS M | 1 | 1 | D | MIKE B | 08-029 |  |  | 09-040 |  | 10-001A | 11-026 | 12-018F | APP | 08-016 |  | 3422 | 0 | 38400 | 3840000 | 100 |  |  |  |  |  |  |  |  |  |
| 13452037o |  | Vend Fab Quads (ARC 10/H-D Q-POLES) Deliver 8 QP Magnets |  | 243d | 2009-08-03 A | 2010-07-26 A | 13452037N FS-163d | 100% |  |  | PROCUREMENT>$50K 69 NO ESCALATION | 56,000 |  | 0 | 56000 | BEVINS M | 1 | 1 | D | MIKE B | 08-029 |  |  | 09-040 |  | 10-001A | 11-026 | 12-018F | APP | 08-016 |  | 3422 | 0 | 56000 | 5600000 | 100 |  |  |  |  |  |  |  |  |  |
| 13452036 |  | Vend Fab Quads (ARC 10/H-D Q-POLES) LABOR Final FY09 |  | 42d | 2009-09-01 A | 2009-10-30 A | 13452035 FS-115d | 100% | 2009-09-01 | 2009-10-29 | MECH DES [25.79 h]; MECH ENG [32.23 h] | 3,238.16 | 3,238.16 | 0 | 3187.2299 | BEVINS M | 1 | 1 | E | MIKE B | 08-029 |  |  | 09-040 | 09-012 | 10-001B | 11-026 | 12-018F | APP | 08-016 |  | 3422 |  |  |  |  | 100 | 100 |  |  |  |  |  |  |  |
| 13453010b |  | Prcrmnt Prep for Correctors (ARC10/H-D Correctors) FY10 |  | 56d | 2009-09-30 A | 2009-12-21 A | 13453010 FS-300d | 100% | 2009-09-30 | 2009-12-18 | MECH ENG [18.28 h]; MECH DES [18.28 h] | 2,029.6 | 2,029.6 | 0 | 2030.7252 | BEVINS M | 1 | 1 | H | MIKE B |  |  |  |  |  | 10-001B | 11-026 | 12-018F |  |  |  |  |  |  |  |  |  |  |  |  |  |  |  |  |  |
| 13452036b |  | Vend Fab Quads (ARC 10/H-D Q-POLES) LABOR Final FY10 |  | 201d | 2009-10-01 A | 2010-07-26 A | 13452036 FS-500d | 100% |  |  | MECH DES [123.4 h]; MECH ENG [154.26 h] | 15,740.64 | 15,740.64 | 0 | 15740.637 | BEVINS M | 1 | 1 | E | MIKE B |  |  |  |  |  | 10-001B | 11-026 | 12-018F | APP |  |  | 3422 |  |  |  |  | 100 | 100 |  |  |  |  |  |  |  |
| 13452045 |  | Mag Measurment of New Quads (ARC 10/H-D Q-POLES) Labor FY10 |  | 160.16d | 2009-11-30 A | 2010-07-26 A | 13452040M FS-600d, 13452038M | 100% |  |  | COMP SCIENT [23.4 h]; OFFICE [23.4 h]; MECH ENG [280.8 h]; MECH TECH [468 h] | 40,094.26 | 40,094.26 | 0 | 40094.262 | BEVINS M | 1 | 1 | H | MIKE B | 08-029 |  |  | 09-040 | 09-012 |  | 11-026 | 12-018F | APP | 08-016 |  |  |  |  |  |  |  |  | 10-030 | 11-001 |  |  |  |  |  |
| 13452045a |  | Mag Measurment of New Quads (ARC 10/H-D Q-POLES) Labor FY11 |  | 160.16d | 2009-11-30 A | 2010-07-26 A | 13452038M, 13452040M FS-600d | 100% |  |  | MECH ENG [199.2 h]; MECH TECH [332 h]; COMP SCIENT [16.6 h]; OFFICE [16.6 h] | 28,442.94 | 28,442.94 | 0 | 29349.796 | BEVINS M | 1 | 1 | H | MIKE B | 08-029 |  |  | 09-040 | 09-012 |  | 11-026 | 12-018F | APP | 08-016 |  |  |  |  |  |  |  |  | 10-030 | 11-001 |  |  |  |  |  |
| 13452045b |  | Mag Measurment of New Quads (ARC 10/H-D Q-POLES) Procurement |  | 160.16d | 2009-11-30 A | 2010-07-26 A | 13452040M FS-600d, 13452038M | 100% |  |  | PROCUREMENT<$50K 60 NO ESCALATION FY11 | 2,637.08 |  | 0 | 2637.082364 | BEVINS M | 1 | 1 | H | MIKE B | 08-029 |  |  | 09-040 | 09-012 |  | 11-026 | 12-018F | APP | 08-016 |  |  | 0 | 2637.082364 | 263708.2364 | 100 |  |  | 10-030 | 11-001 |  |  |  |  |  |
| 13452038M |  | Deliver 1st Article Quadrupoles (ARC 10/H-D Q-POLES) (IPL 534213165) | milestone | 0d | 2009-11-30 A | 2009-11-30 A | 13452037B, 13452030M | 100% | 2009-12-16 | 2009-12-16 |  |  |  |  | 0 | BEVINS M | 1 | 1 | M | MIKE B | 08-029 |  | 6 | 09-040 |  |  | 11-026 | 12-018F |  |  |  |  |  |  |  |  |  |  |  |  | IPL |  |  |  |  |
| 13453020 |  | Vend Fab Correctors (ARC10/H-D Correctors) Labor FY10 |  | 265.14d | 2009-12-21 A | 2011-01-24 A | 13453015M | 100% | 2009-12-28 | 2011-01-24 | MECH ENG [89.66 h]; MECH DES [59.77 h] | 8,682.75 | 8,682.75 | 0 | 8608.1058 | BEVINS M | 1 | 1 | D | MIKE B | 08-029 |  |  |  | 09-012 |  | 11-026 | 12-018F | APP | 08-016 | 08-051 |  |  |  |  |  |  |  |  | 11-001 |  |  |  |  |  |
| 13453020a |  | Vend Fab Correctors (ARC10/H-D Correctors) Labor FY11 |  | 266d | 2009-12-21 A | 2011-01-24 A | 13453015M | 100% | 2009-12-28 | 2011-01-24 | MECH ENG [30.34 h]; MECH DES [20.23 h] | 2,938.57 | 2,938.57 | 0 | 3005.9394 | BEVINS M | 1 | 1 | D | MIKE B | 08-029 |  |  |  | 09-012 |  | 11-026 | 12-018F | APP | 08-016 | 08-051 |  |  |  |  |  |  |  |  | 11-001 |  |  |  |  |  |
| 13453020b |  | Vend Fab Correctors (ARC10/H-D Correctors) Procurement |  | 266d | 2009-12-21 A | 2011-01-24 A | 13453015M | 100% | 2009-12-28 | 2011-01-24 | PROCUREMENT>$50K 69 NO ESCALATION FY11; PROCUREMENT<$50K 60 NO ESCALATION FY11 | 178,023.87 |  | 0 | 178023.87299 | BEVINS M | 1 | 1 | D | MIKE B | 08-029 |  |  |  | 09-012 |  | 11-026 | 12-018F | APP | 08-016 | 08-051 |  | 0 | 178023.87299 | 17802387.299 | 100 |  |  |  | 11-001 |  |  |  |  |  |
| 13453015M |  | Award Contract for Correctors (ARC10/H-D CORRECTORS) | milestone | 0d | 2009-12-21 A | 2009-12-21 A | 9-100M, 13453010b | 100% | 2010-02-26 | 2010-02-26 |  |  |  |  | 0 | BEVINS M | 1 | 1 | M | MIKE B | 08-029 |  | 6 |  |  |  | 11-026 | 12-018F |  |  |  |  |  |  |  |  |  |  |  |  |  | 08-052 |  |  |  |
| 13452040M |  | Delivery Complete for Quadrupoles (ARC 10/H-D Q-POLES) | milestone | 0d | 2010-07-26 A | 2010-07-26 A | 13452037, 13452036b, 13452038M, 13452037T | 100% | 2010-08-19 | 2010-08-19 |  |  |  |  | 0 | BEVINS M | 1 | 1 | M | MIKE B | 08-029 |  | 6 | 09-040 |  |  | 11-026 | 12-018F |  |  |  |  |  |  |  |  |  |  |  |  |  |  |  |  |  |
| 13453030 |  | Mag Measurment of Correctors (ARC10/H-D Correctors) |  | 293d | 2010-09-13 A | 2011-11-14 A | 13453025 FS-70d, 13453015M | 100% |  |  | OFFICE [20 h]; MECH TECH [184 h]; COMP SCIENT [20 h]; MECH ENG [12 h] | 10,585.46 | 10,585.46 | 0 | 10565.48 | BEVINS M | 1 | 1 | H | MIKE B | 08-029 |  |  |  |  |  | 11-026 | 12-018F |  |  |  |  |  |  |  |  |  |  | 10-030 |  |  |  |  |  |  |
| 13452050 |  | Completion of Quadrapole Mag Measurement FY10 |  | 116d | 2010-10-01 A | 2011-03-25 A | 9-100M FS+184d | 100% |  |  | MECH ENG [435.37 h]; MECH TECH [1131.97 h] | 78,337.34 | 78,337.34 | 0 | 75917.5423 | BEVINS M | 1 | 1 | S | MIKE B |  |  |  |  |  |  | 11-026 | 12-018F | APP |  |  |  |  |  |  |  |  |  |  | 11-001 |  |  | ST | 10-065 |  |
| 13452050a |  | Completion of Quadrapole Mag Measurement FY11 |  | 116d | 2010-10-01 A | 2011-03-25 A | 9-100M FS+184d, 13452050 FS-60d | 100% |  |  | MECH ENG [564.63 h]; MECH TECH [1468.03 h] | 101,594.66 | 101,594.66 | 0 | 101594.6606 | BEVINS M | 1 | 1 | S | MIKE B |  |  |  |  |  |  | 11-026 | 12-018F | APP |  |  |  |  |  |  |  |  |  |  | 11-001 |  |  | ST | 10-065 |  |
| 13453025 |  | Delivery Complete for Correctors (ARC10/H-D CORRECTORS) | milestone | 0d | 2011-01-24 A | 2011-01-24 A | 13453020b, 13453020, 13453020a | 100% | 2011-02-09 | 2011-02-09 |  |  |  |  | 0 | BEVINS M | 1 | 1 | Z | MIKE B | 08-029 |  |  |  |  |  | 11-026 | 12-018F |  |  |  |  |  |  |  |  |  |  |  |  |  | 08-052 |  |  |  |
| 13452055 |  | Re-Baseline Actuals Adjustment |  | 1d | 2013-08-30 A | 2013-08-30 A |  | 100% | 2013-09-03 | 2013-09-03 | PROCUREMENT>$50K 69 NO ESCALATION | -60,765.62 |  |  |  |  |  |  |  |  |  |  |  |  |  |  |  |  |  |  |  |  |  |  |  | 100 |  |  |  |  |  |  |  |  | ADJ |

Notes:
- 13452038M: Explanation: IPL from 6 GeV 53421365
- 13452050: Steps: Mechanical measurements P1 (done); Mechanical measurements P2 (done); Harmonics measurements P1 (done); Harmonics measurements P2 (done); Strength measurements P1 (done); Strength measurements P2 (done); Final measurements P1 (done); Final measurements P2 (done); Final approval P1 (done); Final approval P2 (done)
- 13452050a: Steps: Mechanical measurements P1 (done); Mechanical measurements P2 (done); Harmonics measurements P1 (done); Harmonics measurements P2 (done); Strength measurements P1 (done); Strength measurements P2 (done); Final measurements P1 (done); Final measurements P2 (done); Final approval P1 (done); Final approval P2 (done)

| ID | WBS | Activity | Type | Duration | Start | Finish | Predecessors | Complete | Remaining | Planned start | Planned finish | Total float | Free float | Calendar | Resources | Cost | Actual cost | Calculated Remaining Total Cost | MONTHLY EV COST | RESP - Responsibility | STRT%COMP for CM EVM | FNSH%COMP for CM EVM | Profile change | EVMS Reporting Codes | CAM RESPONSIBLE | CR 08-029 | CR 10-030 | CR 10-065 | CR 10-070 | CR 12-035 | LOE Divider | LOE Multiplier | Milestone Level | Remaining Material Cost Based on % Compl | Claimed Material Cost Based on % Complet | Initial Claimed Material Calc | Claimed Material Divider | CR 08-051 | CR 08-016 | CR 09-012 | CR 09-034 | CR 12-018 | CR 08-059 | CR 11-001 | CR 12-015 | CR 11-057 | CR 11-026 | LOE % Pre Calc | LOE % | MARCH!!! | In Progress Procurements | CR 12-039 | ReBaseline Actuals Adjustment | Original Activity ID Rebaseline | PRIOR MONTH EV COST | Activities with Steps | BOE Labor | BOE Expenses | CR 13-015 | Post Rebaseline | Obligated Prior to Rebaseline | CR 14-001 |
| --- | --- | --- | --- | --- | --- | --- | --- | --- | --- | --- | --- | --- | --- | --- | --- | --- | --- | --- | --- | --- | --- | --- | --- | --- | --- | --- | --- | --- | --- | --- | --- | --- | --- | --- | --- | --- | --- | --- | --- | --- | --- | --- | --- | --- | --- | --- | --- | --- | --- | --- | --- | --- | --- | --- | --- | --- | --- | --- | --- | --- | --- | --- |
|  | 3 | **1.3.4.5.3 CORRECTORS** |  |  |  |  |  |  |  |  |  |  |  |  |  |  |  |  |  |  |  |  |  |  |  |  |  |  |  |  |  |  |  |  |  |  |  |  |  |  |  |  |  |  |  |  |  |  |  |  |  |  |  |  |  |  |  |  |  |  |  |  |
|  | 4 | **1.3.4.5.4 STANDS** |  |  | 2009-12-21 | 2013-11-25 |  |  |  |  |  |  |  |  |  |  |  |  |  |  |  |  |  |  |  |  |  |  |  |  |  |  |  |  |  |  |  |  |  |  |  |  |  |  |  |  |  |  |  |  |  |  |  |  |  |  |  |  |  |  |  |  |
| 13454015 |  | Prcrmnt Prep for Arc 10 Stands |  | 57.68d | 2009-12-21 A | 2010-03-22 A | 121456999, 9-110M FS-250d, 121454015a | 100% |  | 2009-12-28 | 2010-03-22 |  |  |  | MECH DES [40 h]; MECH ENG [140 h] | 11,028.6 | 11,028.6 | 0 | 11380.2 | BEVINS M | 1 | 1 | C | H | MIKE B | 08-029 | 10-030 | 10-065 | 10-070 | 12-035F |  |  |  |  |  |  |  |  |  |  |  |  |  |  |  |  |  |  |  |  |  |  |  |  |  |  |  |  |  |  |  |  |
| 13454022LOE |  | Vend Fab Arc 10 Stands Oversight |  | 75d | 2010-03-15 A | 2010-06-28 A | 13454020M | 100% |  |  |  |  |  |  | MECH ENG [20 h]; MECH DES [50 h] | 3,579 | 3,579 | 0 | 3579 | BEVINS M | 1 | 1 |  | E | MIKE B |  | 10-030 | 10-065 | 10-070 | 12-035F | 100 | 100 |  |  |  |  |  |  |  |  |  |  |  |  |  |  |  |  |  |  |  |  |  |  |  |  |  |  |  |  |  |  |
| 13454020M |  | Award Arc 10 Stands | milestone | 0d | 2010-03-22 A | 2010-03-22 A | 13454015 FS-210d | 100% |  | 2010-04-15 | 2010-04-15 |  |  |  |  |  |  |  | 0 | BEVINS M | 1 | 1 |  | M | MIKE B |  | 10-030 | 10-065 | 10-070 | 12-035F |  |  | 6 |  |  |  |  |  |  |  |  |  |  |  |  |  |  |  |  |  |  |  |  |  |  |  |  |  |  |  |  |  |
| 13454025 |  | Vend Fab Arc 10 Stands Phase 1 |  | 72d | 2010-03-22 A | 2010-06-30 A | 13454020M | 100% |  |  |  |  |  |  | PROCUREMENT<$50K 60 | 15,000 |  | 0 | 15000 | BEVINS M | 1 | 1 |  | D | MIKE B | 08-029 | 10-030 | 10-065 | 10-070 | 12-035F |  |  |  | 0 | 15000 | 1500000 | 100 | 08-051 |  |  |  |  |  |  |  |  |  |  |  |  |  |  |  |  |  |  |  |  |  |  |  |  |
| 13454025A |  | Vend Fab Arc 10 Stands Phase 2 |  | 72d | 2010-03-22 A | 2010-06-30 A | 13454025 FS-51d | 100% |  |  |  |  |  |  | PROCUREMENT<$50K 60 | 15,000 |  | 0 | 15000 | BEVINS M | 1 | 1 |  | D | MIKE B |  | 10-030 | 10-065 | 10-070 | 12-035F |  |  |  | 0 | 15000 | 1500000 | 100 |  |  |  |  |  |  |  |  |  |  |  |  |  |  |  |  |  |  |  |  |  |  |  |  |  |
| 13454025B |  | Vend Fab Arc 10 Stands Phase 3 |  | 89d | 2010-03-22 A | 2010-07-26 A | 13454025A FS-64d | 100% |  |  |  |  |  |  | PROCUREMENT<$50K 60 | 15,000 |  | 0 | 15000 | BEVINS M | 1 | 1 |  | D | MIKE B |  | 10-030 | 10-065 | 10-070 | 12-035F |  |  |  | 0 | 15000 | 1500000 | 100 |  |  |  |  |  |  |  |  |  |  |  |  |  |  |  |  |  |  |  |  |  |  |  |  |  |
| 13455015 |  | Proc/Vend Fab Arc 10 Griders (ARC 10/H-D Girders) (Original) |  | 1d | 2010-03-29 A | 2010-03-29 A | 121456999, 9-100M FS+60d, 121455015M | 100% |  |  |  |  |  |  | MECH DES [18.5 h]; MECH TECH [14.8 h]; MECH ENG [8.88 h] | 2,039.44 | 2,039.44 | 0 | 2039.44 | BEVINS M | 1 | 1 |  | H | MIKE B | 08-029 | 10-030 | 10-065 |  |  |  |  |  |  |  |  |  |  | 08-016 | 09-012 | 09-034 |  |  |  |  |  |  |  |  |  |  |  |  |  |  |  |  |  |  |  |  |  |
| 13455020 |  | Proc/Vend Fab H-D Girders (ARC 10/H-D Girders) (Original) |  | 1d | 2010-03-29 A | 2010-03-29 A | 121456999, 121455015M, 9-100M FS+60d | 100% |  |  |  |  |  |  | MECH DES [18.5 h]; MECH TECH [11.1 h]; MECH ENG [8.88 h] | 1,885 | 1,885 | 0 | 1885.002 | BEVINS M | 1 | 1 |  | H | MIKE B | 08-029 | 10-030 | 10-065 |  |  |  |  |  |  |  |  |  | 08-051 | 08-016 | 09-012 | 09-034 |  |  |  |  |  |  |  |  |  |  |  |  |  |  |  |  |  |  |  |  |  |
| 13454031 |  | Prcrmnt Prep for Hall D Girder Floor Plates |  | 56d | 2010-04-12 A | 2010-06-29 A | 9-100M FS+120d | 100% |  |  |  |  |  |  | MECH ENG [12 h] | 790.2 | 790.2 | 0 | 790.2 | BEVINS M | 1 | 1 | C | H | MIKE B |  | 10-030 | 10-065 | 10-070 | 12-035F |  |  |  |  |  |  |  |  |  |  |  | 12-018F |  |  |  |  |  |  |  |  |  |  |  |  |  |  |  |  |  |  |  |  |
| 13455010 |  | Proc Prep For Arc 10 Girders |  | 74d | 2010-04-12 A | 2010-07-26 A | 9-100M FS+122d | 100% |  |  |  |  |  |  | MECH DES [120 h]; MECH ENG [240 h]; MECH TECH [160 h] | 27,911.2 | 27,911.2 | 0 | 27911.2 | BEVINS M | 1 | 1 |  | H | MIKE B | 08-029 | 10-030 | 10-065 |  |  |  |  |  |  |  |  |  |  |  |  | 09-034 |  | 08-059 |  |  |  |  |  |  |  |  |  |  |  |  |  |  |  |  |  |  |  |
| 13454026 |  | Receive and Inspect Arc 10 Stands |  | 39d | 2010-06-01 A | 2010-07-26 A | 13454025, 13454025B FS-24d | 100% |  |  |  |  |  |  | MECH ENG [20 h]; MECH TECH [70 h] | 4,238.8 | 4,238.8 | 0 | 4238.8 | BEVINS M | 1 | 1 |  | U | MIKE B |  | 10-030 | 10-065 | 10-070 | 12-035F |  |  |  |  |  |  |  |  |  |  |  |  |  |  |  |  |  |  |  |  |  |  |  |  |  |  |  |  |  |  |  |  |
| 13454032 |  | Vend fab Hall D Girder Floor Plates |  | 40d | 2010-06-28 A | 2010-08-23 A | 13454031 | 100% |  |  |  |  |  |  | PROCUREMENT<$50K 60 | 4,100 |  | 0 | 4100 | BEVINS M | 1 | 1 | C | D | MIKE B |  | 10-030 | 10-065 | 10-070 | 12-035F |  |  |  | 0 | 4100 | 410000 | 100 |  |  |  |  | 12-018F |  |  |  |  |  |  |  |  |  |  |  |  |  |  |  |  |  |  |  |  |
| 13455023 |  | Vend Fab Arc 10 Girders Oversight FY10 |  | 88.59d | 2010-07-19 A | 2010-11-19 A | 13455010 | 100% |  |  |  |  |  |  | MECH DES [35.73 h]; MECH ENG [23.82 h] | 3,225.74 | 3,225.74 | 0 | 3184.9722 | BEVINS M | 1 | 1 |  | E | MIKE B |  | 10-030 | 10-065 |  |  | 100 | 100 |  |  |  |  |  |  |  |  |  |  |  | 11-001 |  |  |  |  |  |  |  |  |  |  |  |  |  |  |  |  |  |  |
| 13455023a |  | Vend Fab Arc 10 Girders Oversight FY11 |  | 89d | 2010-07-19 A | 2010-11-19 A | 13455010 | 100% |  |  |  |  |  |  | MECH DES [24.27 h]; MECH ENG [16.18 h] | 2,191.31 | 2,191.31 | 0 | 2232.3546 | BEVINS M | 1 | 1 |  | E | MIKE B |  | 10-030 | 10-065 |  |  | 100 | 100 |  |  |  |  |  |  |  |  |  |  |  | 11-001 |  |  |  |  |  |  |  |  |  |  |  |  |  |  |  |  |  |  |
| 13454030M |  | Delivery Complete for Arc 10 Stands | milestone | 0d | 2010-07-26 A | 2010-07-26 A | 13454026 | 100% |  | 2010-08-26 | 2010-08-26 |  |  |  |  |  |  |  | 0 | BEVINS M | 1 | 1 |  | M | MIKE B |  | 10-030 | 10-065 | 10-070 | 12-035F |  |  | 6 |  |  |  |  |  |  |  |  |  |  |  |  |  |  |  |  |  |  |  |  |  |  |  |  |  |  |  |  |  |
| 13455130 |  | Proc Prep Tagger Dump Enclosure |  | 22d | 2010-07-30 A | 2010-08-30 A | 9-100M FS+205d | 100% |  |  |  |  |  |  | MECH ENG [80 h]; MECH DES [160 h] | 12,506.4 | 12,506.4 | 0 | 12506.4 | BEVINS M | 1 | 1 |  | H | MIKE B |  |  | 10-065 |  |  |  |  |  |  |  |  |  |  |  |  |  |  |  |  | 12-015 |  |  |  |  |  |  |  |  |  |  |  |  |  |  |  |  |  |
| 13455140 |  | Proc Prep Hall D Movaable Shield Wall FY10 |  | 41d | 2010-07-30 A | 2010-09-27 A | 9-100M FS+205d | 100% |  |  |  |  |  |  | MECH ENG [103.2 h]; MECH DES [206.4 h] | 16,133.26 | 16,133.26 | 0 | 16133.256 | BEVINS M | 1 | 1 |  | H | MIKE B |  |  | 10-065 |  |  |  |  |  |  |  |  |  |  |  |  |  |  |  | 11-001 | 12-015 |  |  |  |  |  |  |  |  |  |  |  |  |  |  |  |  |  |
| 13455140a |  | Proc Prep Hall D Movaable Shield Wall FY11 |  | 41d | 2010-07-30 A | 2010-09-27 A | 9-100M FS+205d | 100% |  |  |  |  |  |  | MECH ENG [16.8 h]; MECH DES [33.6 h] | 2,626.34 | 2,626.34 | 0 | 2710.008 | BEVINS M | 1 | 1 |  | H | MIKE B |  |  | 10-065 |  |  |  |  |  |  |  |  |  |  |  |  |  |  |  | 11-001 | 12-015 |  |  |  |  |  |  |  |  |  |  |  |  |  |  |  |  |  |
| 13454042 |  | Prcrmnt Prep for Alignment Cartridges (ARC10/H-D Stands) FY10 |  | 74.81d | 2010-08-02 A | 2010-11-15 A | 9-100M FS+205d | 100% |  |  |  |  |  |  | MECH ENG [43.54 h]; MECH DES [4.35 h] | 3,105.45 | 3,105.45 | 0 | 3063.903 | BEVINS M | 1 | 1 | C | H | MIKE B |  | 10-030 |  |  |  |  |  |  |  |  |  |  |  |  |  |  |  |  | 11-001 |  |  |  |  |  |  |  |  |  |  |  |  |  |  |  |  |  |  |
| 13454042a |  | Prcrmnt Prep for Alignment Cartridges (ARC10/H-D Stands) FY11 |  | 75d | 2010-08-02 A | 2010-11-15 A | 9-100M FS+205d | 100% |  |  |  |  |  |  | MECH ENG [36.46 h]; MECH DES [3.65 h] | 2,600.93 | 2,600.93 | 0 | 2647.839 | BEVINS M | 1 | 1 | C | H | MIKE B |  | 10-030 |  |  |  |  |  |  |  |  |  |  |  |  |  |  |  |  | 11-001 |  |  |  |  |  |  |  |  |  |  |  |  |  |  |  |  |  |  |
| 13455025 |  | Vend Fab Arc 10 Girders Phase 1 |  | 75d | 2010-08-02 A | 2010-11-15 A | 13455010 | 100% |  |  |  |  |  |  | PROCUREMENT>$50K 69 NO ESCALATION FY11; PROCUREMENT<$50K 60 NO ESCALATION FY11 | 92,188 |  | 0 | 92188 | BEVINS M | 1 | 1 |  | D | MIKE B |  | 10-030 | 10-065 |  |  |  |  |  | 0 | 92188 | 9218800 | 100 |  |  |  |  |  |  |  |  |  |  |  |  |  |  |  |  |  |  |  |  |  |  |  |  |  |
| 13455075 |  | Prcrmnt Prep for Hall D Stands Part 1 |  | 11d | 2010-08-09 A | 2010-08-23 A | 9-100M FS+162d | 100% |  |  |  |  |  |  | MECH DES [20 h]; MECH ENG [40 h] | 3,538.8 | 3,538.8 | 0 | 3538.8 | BEVINS M | 1 | 1 | C | H | MIKE B |  | 10-030 | 10-065 | 10-070 | 12-035F |  |  |  |  |  |  |  |  |  |  |  | 12-018F |  |  |  | 11-057 |  |  |  |  |  |  |  |  |  |  |  |  |  |  |  |  |
| 13454035 |  | Proc Misc Brackets & Hardware (ARC10/H-D Stands) |  | 514d | 2010-08-23 A | 2012-09-17 A | 9-110M FS-25d, 121456999 | 100% |  |  |  |  |  |  | MECH DES [120 h]; PROCUREMENT<$50K 60; MECH ENG [100 h] | 21,629.71 | 12,559.02 | 0 | 21467.29 | BEVINS M | 1 | 1 |  | H | MIKE B |  | 10-030 | 10-065 | 10-070 | 12-035F |  |  |  | 0 | 9070.69 | 907069 | 100 |  |  |  |  |  |  |  |  |  |  |  |  |  |  |  |  |  |  |  |  |  |  |  |  |  |
| 13455135 |  | Vend Fab Tagger Dump Enclosure |  | 20d | 2010-08-23 A | 2010-09-20 A | 13455130 | 100% |  |  |  |  |  |  | PROCUREMENT<$50K 60 NO ESCALATION FY11 | 12,000 |  | 0 | 12000 | BEVINS M | 1 | 1 |  | D | MIKE B |  |  | 10-065 |  |  |  |  |  | 0 | 12000 | 1200000 | 100 |  |  |  |  |  |  |  | 12-015 |  |  |  |  |  |  |  |  |  |  |  |  |  |  |  |  |  |
| 13455028 |  | Vend Fab Arc 10 Girders Phase 2 |  | 130d | 2010-09-13 A | 2011-03-25 A | 13455025 FS-20d | 100% |  |  |  |  |  |  | PROCUREMENT>$50K 69 NO ESCALATION FY11 | 92,188 |  | 0 | 92188 | BEVINS M | 1 | 1 |  | D | MIKE B |  | 10-030 | 10-065 |  |  |  |  |  | 0 | 92188 | 9218800 | 100 |  |  |  |  |  |  |  |  |  |  |  |  |  |  |  |  |  |  |  |  |  |  |  |  |  |
| 13455035 |  | Vend Fab Hall D Floor Girders |  | 116d | 2010-10-01 A | 2011-03-25 A | 9-100M FS+210d, 9-110M | 100% |  |  |  |  |  |  | PROCUREMENT>$50K 69 NO ESCALATION FY11 | 34,000 |  | 0 | 34000 | BEVINS M | 1 | 1 |  | D | MIKE B |  | 10-030 | 10-065 |  |  |  |  |  | 0 | 34000 | 3400000 | 100 |  |  |  |  |  |  |  |  |  |  |  |  |  |  |  |  |  |  |  |  |  |  |  |  |  |
| 13455115 |  | Proc Prep Arc 10 Floor to Ceiling Stands |  | 252d | 2010-10-11 A | 2011-10-15 A | 9-100M FS+165d | 100% |  | 2010-10-11 | 2011-10-14 |  |  |  | MECH DES [40 h]; MECH ENG [160 h] | 12,755.35 | 12,755.35 | 0 | 12345.6 | BEVINS M | 1 | 1 |  | H | MIKE B |  | 10-030 | 10-065 | 10-070 | 12-035F |  |  |  |  |  |  |  |  |  |  |  |  |  |  |  |  |  |  |  |  |  |  |  |  |  |  |  |  |  |  |  |  |
| 13455030 |  | Receive and Inspect Arc 10 Girders |  | 85d | 2010-11-15 A | 2011-03-25 A | 13455025, 13455028 FS-60d | 100% |  |  |  |  |  |  | MECH ENG [8 h]; MECH TECH [80 h] | 3,989.2 | 3,989.2 | 0 | 3989.2 | BEVINS M | 1 | 1 |  | U | MIKE B |  | 10-030 | 10-065 |  |  |  |  |  |  |  |  |  |  |  |  |  |  |  |  |  |  |  |  |  |  |  |  |  |  |  |  |  |  |  |  |  |  |
| 13454045 |  | Vend Fab Alignment Cartridges (ARC10/H-D Stands) |  | 49d | 2010-12-03 A | 2011-02-21 A | 13454042a, 13454042 | 100% |  | 2010-12-03 | 2011-02-18 |  |  |  | PROCUREMENT<$50K 60 | 61,737.79 |  | 0 | 61737.79 | BEVINS M | 1 | 1 | C | D | MIKE B | 08-029 | 10-030 |  |  |  |  |  |  | 0 | 61737.79 | 6173779 | 100 | 08-051 |  | 09-012 |  |  |  |  |  |  |  |  |  |  |  |  |  |  |  |  |  |  |  |  |  |  |
| 13455040 |  | Proc Prep For Hall D Girders |  | 133d | 2010-12-03 A | 2011-06-20 A | 9-110M FS+43d | 100% |  |  |  |  |  |  | MECH ENG [80 h]; MECH DES [40 h] | 7,303.2 | 7,303.2 | 0 | 7303.2 | BEVINS M | 1 | 1 |  | H | MIKE B |  | 10-030 |  |  |  |  |  |  |  |  |  |  |  |  |  |  | 12-018F |  |  |  |  | 11-026 |  |  |  |  |  |  |  |  |  |  |  |  |  |  |  |
| 13454047 |  | Receive and Inspect Alignment Cartridges (ARC10/H-D Stands) |  | 24d | 2011-02-21 A | 2011-03-25 A | 13454045 FS-10d | 100% |  | 2011-02-22 | 2011-03-25 |  |  |  | MECH TECH [20 h] | 861.4 | 861.4 | 0 | 861.4 | BEVINS M | 1 | 1 | C | U | MIKE B |  | 10-030 |  |  |  |  |  |  |  |  |  |  |  |  |  |  |  |  |  |  |  |  |  |  |  |  |  |  |  |  |  |  |  |  |  |  |  |
| 13455045 |  | Vend Fab Hall D Girders Oversight |  | 158d | 2011-03-01 A | 2011-10-11 A | 13455040 FS-20d | 100% |  |  |  |  |  |  | MECH DES [60 h]; MECH ENG [40 h] | 5,526.61 | 5,526.61 | 0 | 5518.8 | BEVINS M | 1 | 1 |  | H | MIKE B |  | 10-030 |  |  |  |  |  |  |  |  |  |  |  |  |  |  | 12-018F |  |  |  |  | 11-026 |  |  |  |  |  |  |  |  |  |  |  |  |  |  |  |
| 13455050 |  | Vend Fab Hall D Girders Part 1 |  | 40d | 2011-03-01 A | 2011-04-25 A | 13455040 FS-20d | 100% |  |  |  |  |  |  | PROCUREMENT<$50K 60 | 30,052.02 |  | 0 | 30052.02 | BEVINS M | 1 | 1 |  | D | MIKE B |  | 10-030 |  |  |  |  |  |  | 0 | 30052.02 | 3005202 | 100 |  |  |  |  | 12-018F |  |  |  |  | 11-026 |  |  |  |  |  |  |  |  |  |  |  |  |  |  |  |
| 13455060 |  | Receive and Inspect Hall D Girders |  | 135d | 2011-04-01 A | 2011-10-11 A | 13455055 FS-125d, 13455050 | 100% |  |  |  |  |  |  | MECH ENG [8 h]; MECH TECH [60 h] | 3,132.96 | 3,132.96 | 0 | 3127.8 | BEVINS M | 1 | 1 |  | U | MIKE B |  | 10-030 |  |  |  |  |  |  |  |  |  |  |  |  |  |  | 12-018F |  |  |  |  | 11-026 |  |  |  |  |  |  |  |  |  |  |  |  |  |  |  |
| 13455055 |  | Vend Fab Hall D Girders Part 2 |  | 75d | 2011-06-30 A | 2011-10-15 A | 13455050 FS-78d | 100% |  | 2011-06-30 | 2011-10-14 |  |  |  | PROCUREMENT<$50K 60; PROCUREMENT>$50K 69 | 30,052.03 |  | 0 | 30052.03 | BEVINS M | 1 | 1 |  | D | MIKE B |  | 10-030 |  |  |  |  |  |  | 0 | 30052.03 | 3005203 | 100 |  |  |  |  | 12-018F |  |  |  |  | 11-026 |  |  |  |  |  |  |  |  |  |  |  |  |  |  |  |
| 13454036 |  | Prcrmnt Prep for Insertable Dumps (ARC10/H-D Stands) |  | 26d | 2011-10-10 A | 2011-11-14 A | 9-120M, 9-110M FS+60d | 100% |  |  |  |  |  |  | MECH ENG [120 h]; MECH DES [16 h] | 9,185.12 | 9,185.12 | 0 | 8900.88 | BEVINS M | 1 | 1 | C | H | MIKE B |  | 10-030 |  |  |  |  |  |  |  |  |  |  |  |  |  |  |  |  |  |  | 11-057 |  |  |  |  |  |  |  |  |  |  |  |  |  |  |  |  |
| 13455120 |  | Vend Fab Arc 10 Floor to Ceiling Stands |  | 57d | 2011-10-17 A | 2012-01-16 A | 13455115 | 100% |  | 2011-10-17 | 2012-01-13 |  |  |  | PROCUREMENT<$50K 60 | 15,478.5 |  | 0 | 15478.5 | BEVINS M | 1 | 1 |  | D | MIKE B |  | 10-030 | 10-065 | 10-070 | 12-035F |  |  |  | 0 | 15478.5 | 1547850 | 100 |  |  |  |  |  |  |  |  |  |  |  |  |  |  |  |  |  |  |  |  |  |  |  |  |  |
| 13454040 |  | Vend Fab Insertable Dumps (ARC10/H-D Stands) |  | 101d | 2011-11-14 A | 2012-04-16 A | 9-120M, 13454036 | 100% |  |  |  |  |  |  | PROCUREMENT<$50K 60 | 25,740.14 |  | 0 | 25740.14 | BEVINS M | 1 | 1 |  | D | MIKE B | 08-029 | 10-030 |  |  |  |  |  |  | 0 | 25740.14 | 2574014 | 100 |  |  |  |  |  |  |  |  | 11-057 |  |  |  |  |  |  |  |  |  |  |  |  |  |  |  |  |
| 13455080 |  | Prcrmnt Prep for Hall D Stands Part 2 |  | 85d | 2012-01-03 A | 2012-05-02 A | 9-120M FS+60d, 13455075 | 100% |  |  |  |  |  |  | MECH DES [60 h]; MECH ENG [120 h] | 11,304.6 | 11,304.6 | 0 | 10954.8 | BEVINS M | 1 | 1 | C | H | MIKE B |  |  | 10-065 |  | 12-035F |  |  |  |  |  |  |  |  |  |  |  | 12-018F |  |  |  | 11-057 |  |  |  |  |  |  |  |  |  |  |  |  |  |  |  |  |
| 13455125 |  | Receive and Inspect Arc 10 Floor to Ceiling Stands |  | 5d | 2012-01-16 A | 2012-01-23 A | 13455120 FS-10d | 100% |  | 2012-01-17 | 2012-01-23 |  |  |  | MECH ENG [40 h]; MECH TECH [80 h] | 6,360 | 6,360 | 0 | 6163.6 | BEVINS M | 1 | 1 |  | U | MIKE B |  | 10-030 | 10-065 | 10-070 | 12-035F |  |  |  |  |  |  |  |  |  |  |  |  |  |  |  |  |  |  |  |  |  |  |  |  |  |  |  |  |  |  |  |  |
| 13455085LOE |  | Vend Fab Hall D Stands Oversight |  | 73d | 2012-01-18 A | 2012-04-30 A | 13455080M FS-55d | 100% |  |  |  |  |  |  | MECH ENG [20 h]; MECH DES [50 h] | 3,810.9 | 3,810.9 | 0 | 3810.9 | BEVINS M | 1 | 1 |  | E | MIKE B |  | 10-030 | 10-065 | 10-070 | 12-035F | 100 | 100 |  |  |  |  |  |  |  |  |  | 12-018F |  |  |  | 11-057 |  | 28.76712328 | 71.23287671 |  |  |  |  |  |  |  |  |  |  |  |  |  |
| 13454050 |  | 100 kW dump Modifications (ARC10/H-D Stands) Original |  | 197d | 2012-03-20 A | 2013-03-11 A | 9-120M FS+85d, 13458030 FS-18d | 100% |  | 2012-03-20 | 2013-01-03 |  |  |  | MECH ENG [60 h]; MECH DES [40 h]; MECH TECH [40 h] | 7,989.88 | 8,022.33 | 0 | 7667 | BEVINS M | 1 | 1 |  | H | MIKE B | 08-029 | 10-030 |  |  |  |  |  |  |  |  |  |  |  |  | 09-012 |  |  |  |  |  | 11-057 |  |  |  | XX |  |  |  |  |  |  |  |  |  |  |  |  |
| 13455145 |  | Vend Fab Hall D Movable Shield Wall |  | 148d | 2012-04-16 A | 2012-11-12 A | 13455140, 13455140a, 9-120M FS+125d, 9-110M FS+100d | 100% |  |  |  |  |  |  | PROCUREMENT<$50K 60 | 41,276 |  | 0 | 41276 | BEVINS M | 1 | 1 |  | D | MIKE B |  |  | 10-065 |  |  |  |  |  | 0 | 41276 | 4127600 | 100 |  |  |  |  |  |  |  | 12-015 |  |  |  |  |  | Split |  |  |  |  |  |  |  |  |  |  |  |
| 13455080M |  | Award Hall D Stands | milestone | 0d | 2012-06-02 A | 2012-06-02 A | 13455080, 9-120M FS+150d | 100% |  | 2012-07-02 | 2012-07-02 |  |  |  |  |  |  |  | 0 | BEVINS M | 1 | 1 |  | M | MIKE B |  | 10-030 | 10-065 | 10-070 | 12-035F |  |  | 6 |  |  |  |  |  |  |  |  | 12-018F |  |  |  | 11-057 |  |  |  |  |  |  |  |  |  |  |  |  |  |  |  |  |
| 13455090 |  | Vend Fab Hall D Stands |  | 134d | 2012-06-05 A | 2013-05-13 A | 13455080M FS+8d | 100% |  | 2012-06-05 | 2012-12-12 |  |  |  | PROCUREMENT<$50K 60; PROCUREMENT>$50K 69 | 88,823.6 |  | 0 | 88823.6 | BEVINS M | 1 | 1 |  | D | MIKE B |  | 10-030 | 10-065 | 10-070 | 12-035 |  |  |  | 0 | 88823.6 | 8882360 | 100 |  |  |  |  | 12-018F |  |  |  | 11-057 |  |  |  | XX | Split | 12-039 |  |  |  |  |  |  |  |  |  |  |
| 13455105 |  | Receive and Inspect Hall D Stands |  | 74d | 2012-09-10 A | 2013-05-13 A | 13455090 FS-39d | 100% |  | 2012-09-10 | 2012-12-31 |  |  |  | MECH ENG [20 h]; MECH TECH [70 h] | 4,628.17 | 4,644.37 | 0 | 4513.2 | BEVINS M | 1 | 1 |  | U | MIKE B |  | 10-030 | 10-065 | 10-070 | 12-035F |  |  |  |  |  |  |  |  |  |  |  | 12-018F |  |  |  | 11-057 |  |  |  | XX |  |  |  |  |  |  |  |  |  |  |  |  |
| 13454055 |  | 100 kW dump Modifications (ARC10/H-D Stands) Revised |  | 76d | 2013-05-03 A | 2013-08-30 A | 9-130M FS+80d, 9-120M FS+85d, 13454050 | 100% |  | 2013-06-03 | 2013-09-18 |  |  |  | MECH DES [120 h]; MECH TECH [120 h]; MECH ENG [180 h]; PROCUREMENT<$50K 60 | 46,854.37 | 24,493.2 | 23047.985 | 46095.97 | BEVINS M | 1 | 1 |  | H | MIKE B | 08-029 | 10-030 |  |  |  |  |  |  | 0 | 22361.17 | 2236117 | 100 |  |  | 09-012 |  |  |  |  |  | 11-057 |  |  |  |  |  |  |  |  |  |  |  |  |  |  |  |  |
| 13455110M |  | Delivery Complete for Hall D Stands | milestone | 0d | 2013-05-13 A | 2013-05-13 A | 13455105, 13455090 | 100% |  | 2013-06-24 | 2013-06-24 |  |  |  |  |  |  |  | 0 | BEVINS M | 1 | 1 |  | M | MIKE B |  | 10-030 | 10-065 | 10-070 | 12-035 |  |  | 6 |  |  |  |  |  |  |  |  | 12-018F |  |  |  | 11-057 |  |  |  | XX |  |  |  |  |  |  |  |  |  |  |  |  |
| 13454060 |  | Re-Baseline Actuals Adjustment |  | 1d | 2013-08-30 A | 2013-08-30 A |  | 100% |  | 2013-09-03 | 2013-09-03 |  |  |  | PROCUREMENT>$50K 69 NO ESCALATION | 102,433.65 |  |  | 102433.65 |  |  |  |  |  |  |  |  |  |  |  |  |  |  | 0 | 102433.65 | 10243365 | 100 |  |  |  |  |  |  |  |  |  |  |  |  |  |  |  | ADJ |  |  |  |  |  |  |  |  |  |
| 23454055 |  | 100 kW dump Modifications (ARC10/H-D Stands) Procurement |  | 37d | 2013-09-03 A | 2013-11-25 | 9-130M FS+228d | 50% | 17d | 2013-10-01 | 2013-11-20 | 65d | 3d | 8/5 M-F w/JLAB Holidays ReBaseline | MECH TECH; MECH DES; MECH ENG; SUPPLIES & MATERIALS; PROCUREMENT<$50K 60 | 2,999.36 |  |  | 0 | BEVINS M | 1 | 1 |  | S | MIKE B | 08-029 | 10-030 |  |  |  |  |  |  | 1499.68 | 1499.68 | 149968 | 100 |  |  | 09-012 |  |  |  |  |  | 11-057 |  |  |  |  |  |  |  | 23454055 | 1499.68 | ST | EJ | EJ | 13-015 | PR | OB |  |
| 23454055a |  | 100 kW dump Modifications (ARC10/H-D Stands) Labor/Expenses FY13 |  | 20d | 2013-09-03 A | 2013-11-25 | 9-130M FS+228d | 50% | 17d | 2013-10-01 | 2013-10-28 | 68d | 3d | 8/5 M-F w/JLAB Holidays ReBaseline | MECH TECH [19.46 h]; MECH DES [19.46 h]; MECH ENG [29.19 h]; SUPPLIES & MATERIALS | 11,536.61 | 2,147.02 |  | 0 | BEVINS M | 1 | 1 |  | S | MIKE B | 08-029 | 10-030 |  |  |  |  |  |  |  |  |  |  |  |  | 09-012 |  |  |  |  |  | 11-057 |  |  |  |  |  |  |  | 23454055 | 5704.9103 | ST | EJ | EJ | 13-015 | PR |  |  |
| 23454055b |  | 100 kW dump Modifications (ARC10/H-D Stands) Labor/Expenses FY14 |  | 17d | 2013-09-03 A | 2013-11-25 | 23454055a FS-20d | 50% | 17d | 2013-10-29 | 2013-11-20 | 65d | 3d | 8/5 M-F w/JLAB Holidays ReBaseline | MECH TECH [16.54 h]; MECH DES [16.54 h]; MECH ENG [24.81 h]; SUPPLIES & MATERIALS | 10,007.57 | 1,824.85 |  | 0 | BEVINS M | 1 | 1 |  | S | MIKE B | 08-029 | 10-030 |  |  |  |  |  |  |  |  |  |  |  |  | 09-012 |  |  |  |  |  | 11-057 |  |  |  |  |  |  |  | 23454055 | 5003.78875 | ST | EJ | EJ | 13-015 | PR |  | 14-001 |

Notes:
- 23454055: Explanation: $2,999 is for stands / Steps: Fabricate diffuser window (done); Copper skid rework; Aluminum skid rework
- 23454055a: Explanation: $2,999 is for stands / Steps: Fabricate diffuser window (done); Copper skid rework; Aluminum skid rework
- 23454055b: Explanation: $2,999 is for stands / Steps: Fabricate diffuser window (done); Copper skid rework; Aluminum skid rework

| ID | WBS | Activity | Type | Duration | Start | Finish | Predecessors | Complete | Remaining | Planned start | Planned finish | Total float | Free float | Calendar | Resources | Cost | Actual cost | Calculated Remaining Total Cost | MONTHLY EV COST | RESP - Responsibility | STRT%COMP for CM EVM | FNSH%COMP for CM EVM | EVMS Reporting Codes | CAM RESPONSIBLE | CR 10-030 | CR 10-065 | CR 11-026 | CR 12-018 | Profile change | Remaining Material Cost Based on % Compl | Claimed Material Cost Based on % Complet | Initial Claimed Material Calc | Claimed Material Divider | Milestone Level | LOE Divider | LOE Multiplier | CR 11-001 | CR 10-070 | CR 12-035 | CR 08-029 | CR 09-012 | MARCH!!! | CR 08-051 | Installation | CR 11-057 | ReBaseline Actuals Adjustment | CR 08-052 | CR 08-016 | Activities with Steps | CR 10-059 | H activities to change code | Specification | Original Activity ID Rebaseline | PRIOR MONTH EV COST | BOE Labor | CR 13-015 | Post Rebaseline | CR 14-001 |
| --- | --- | --- | --- | --- | --- | --- | --- | --- | --- | --- | --- | --- | --- | --- | --- | --- | --- | --- | --- | --- | --- | --- | --- | --- | --- | --- | --- | --- | --- | --- | --- | --- | --- | --- | --- | --- | --- | --- | --- | --- | --- | --- | --- | --- | --- | --- | --- | --- | --- | --- | --- | --- | --- | --- | --- | --- | --- | --- |
|  | 5 | **1.3.4.5.5 GIRDERS** |  |  |  |  |  |  |  |  |  |  |  |  |  |  |  |  |  |  |  |  |  |  |  |  |  |  |  |  |  |  |  |  |  |  |  |  |  |  |  |  |  |  |  |  |  |  |  |  |  |  |  |  |  |  |  |  |
|  | 6 | **1.3.4.5.6 VACUUM** |  |  | 2010-01-15 | 2013-08-30 |  |  |  |  |  |  |  |  |  |  |  |  |  |  |  |  |  |  |  |  |  |  |  |  |  |  |  |  |  |  |  |  |  |  |  |  |  |  |  |  |  |  |  |  |  |  |  |  |  |  |  |  |
| 13456015 |  | Prcrmnt Prep for Dipole Chambers (ARC 10/H-D Vac) |  | 133d | 2010-01-15 A | 2010-07-26 A | 9-110M FS-250d, 121456015, 121456999 | 100% |  |  |  |  |  |  | MECH DES [20 h]; MECH ENG [120 h] | 8,806.8 | 8,806.8 | 0 | 9087.6 | BEVINS M | 1 | 1 | H | MIKE B |  |  |  |  |  |  |  |  |  |  |  |  |  |  |  |  |  |  |  |  |  |  |  |  |  |  |  |  |  |  |  |  |  |  |
| 13456032 |  | Prcrmnt Prep of Ion Pumps & Vac Valves (ARC 10/H-D Vac) |  | 315d | 2010-06-21 A | 2011-09-24 A | 9-100M FS+129d | 100% |  | 2010-06-21 | 2011-09-23 |  |  |  | MECH DES [40 h]; MECH ENG [80 h] | 7,251.63 | 7,251.63 | 0 | 7077.6 | BEVINS M | 1 | 1 | H | MIKE B | 10-030 | 10-065 | 11-026 | 12-018F |  |  |  |  |  |  |  |  |  |  |  |  |  |  |  |  |  |  |  |  |  |  |  |  |  |  |  |  |  |  |
| 13456037 |  | Prcrmnt Prep of Bellows & Drift tubes (ARC 10/H-D Vac) |  | 69d | 2010-06-21 A | 2010-09-27 A | 9-100M FS+148d | 100% |  |  |  |  |  |  | MECH ENG [80 h]; MECH DES [60 h] | 7,982.4 | 7,982.4 | 0 | 7982.4 | BEVINS M | 1 | 1 | H | MIKE B | 10-030 | 10-065 |  |  | C |  |  |  |  |  |  |  |  |  |  |  |  |  |  |  |  |  |  |  |  |  |  |  |  |  |  |  |  |  |
| 13456025 |  | Vend Fab Dipole Chambers (ARC 10/H-D Vac) Phase 1 |  | 66d | 2010-06-28 A | 2010-09-29 A | 13456020M FS-20d | 100% |  |  |  |  |  |  | PROCUREMENT<$50K 60 NO ESCALATION FY11 | 33,879 |  | 0 | 33879 | BEVINS M | 1 | 1 | D | MIKE B | 10-030 |  |  |  |  | 0 | 33879 | 3387900 | 100 |  |  |  |  |  |  |  |  |  |  |  |  |  |  |  |  |  |  |  |  |  |  |  |  |  |
| 13456020M |  | Award Contract for Dipole Chambers (ARC 10/H-D VACUUM) | milestone | 0d | 2010-07-27 A | 2010-07-27 A | 13456015 | 100% |  | 2010-08-27 | 2010-08-27 |  |  |  |  |  |  |  | 0 | BEVINS M | 1 | 1 | M | MIKE B | 10-030 |  |  |  |  |  |  |  |  | 6 |  |  |  |  |  |  |  |  |  |  |  |  |  |  |  |  |  |  |  |  |  |  |  |  |
| 13456022LOE |  | Vend Fab Dipole Chambers (ARC 10/H-D Vac) Oversight FY10 |  | 149.21d | 2010-07-30 A | 2011-03-11 A | 13456020M FS-20d | 100% |  |  |  |  |  |  | MECH DES [11.73 h]; MECH ENG [23.47 h] | 2,122.83 | 2,122.83 | 0 | 2076.1647 | BEVINS M | 1 | 1 | E | MIKE B | 10-030 |  |  |  |  |  |  |  |  |  | 100 | 100 | 11-001 |  |  |  |  |  |  |  |  |  |  |  |  |  |  |  |  |  |  |  |  |  |
| 13456022LOEa |  | Vend Fab Dipole Chambers (ARC 10/H-D Vac) Oversight FY11 |  | 150d | 2010-07-30 A | 2011-03-11 A | 13456020M FS-20d, 13456022LOE | 100% |  |  |  |  |  |  | MECH ENG [56.53 h]; MECH DES [28.27 h] | 5,114.09 | 5,114.09 | 0 | 5160.8571 | BEVINS M | 1 | 1 | E | MIKE B | 10-030 |  |  |  |  |  |  |  |  |  | 100 | 100 | 11-001 |  |  |  |  |  |  |  |  |  |  |  |  |  |  |  |  |  |  |  |  |  |
| 13456027 |  | Vend Fab Dipole Chambers (ARC 10/H-D Vac) Phase 2 |  | 56d | 2010-09-27 A | 2010-12-15 A | 13456025 FS-80d | 100% |  |  |  |  |  |  | PROCUREMENT<$50K 60 NO ESCALATION FY11; PROCUREMENT>$50K 69 NO ESCALATION FY11 | 33,879 |  | 0 | 33879 | BEVINS M | 1 | 1 | D | MIKE B | 10-030 |  |  | 12-018F |  | 0 | 33879 | 3387900 | 100 |  |  |  |  | 10-070 | 12-035F |  |  |  |  |  |  |  |  |  |  |  |  |  |  |  |  |  |  |  |
| 13456040 |  | Prcrmnt of Bellows & Drift tubes (ARC 10/H-D Vac) |  | 101d | 2010-09-27 A | 2011-02-28 A | 13456037 | 100% |  |  |  |  |  |  | PROCUREMENT<$50K 60 NO ESCALATION FY11 | 59,935 |  | 0 | 59935 | BEVINS M | 1 | 1 | D | MIKE B | 10-030 | 10-065 |  |  | C | 0 | 59935 | 5993500 | 100 |  |  |  |  |  |  | 08-029 | 09-012 |  |  |  |  |  |  |  |  |  |  |  |  |  |  |  |  |  |
| 13456029 |  | Receive and Inspect Dipole Chambers (ARC 10/H-D Vac) |  | 511d | 2010-12-03 A | 2013-01-24 A | 13456028 FS-120d, 13456025 | 100% |  | 2010-12-03 | 2012-12-31 |  |  |  | MECH TECH [80 h]; MECH ENG [20 h] | 4,914.51 | 4,920.26 | 0 | 4804.6 | BEVINS M | 1 | 1 | U | MIKE B | 10-030 |  |  | 12-018F |  |  |  |  |  |  |  |  |  | 10-070 | 12-035F |  |  | XX |  |  |  |  |  |  |  |  |  |  |  |  |  |  |  |  |
| 13456045 |  | Assemble Quad Girders for Arc10 & Hall D on Floor (ARC 10/H-D Vac) |  | 269d | 2010-12-14 A | 2012-01-22 A | 13455023, 13455015, 13455035 FS-5d, 13455020, 13456040 FS-55d, 13455030 FS-40d, 13455023a | 100% |  | 2010-12-14 | 2012-01-20 |  |  |  | MECH TECH [760 h]; PROCUREMENT<$50K 60; MECH ENG [40 h]; MECH DES [60 h] | 62,384.41 | 38,573.32 | 0 | 62063.09 | BEVINS M | 1 | 1 | U | MIKE B | 10-030 | 10-065 |  |  |  | 0 | 23811.09 | 2381109 | 100 |  |  |  |  |  |  | 08-029 |  |  | 08-051 | Install |  |  |  |  |  |  |  |  |  |  |  |  |  |  |
| 13456028 |  | Vend Fab Dipole Chambers (ARC 10/H-D Vac) Phase 3 |  | 502d | 2010-12-16 A | 2013-01-24 A | 13456027 FS-112d | 100% |  | 2010-12-16 | 2012-12-31 |  |  |  | PROCUREMENT>$50K 69 NO ESCALATION FY11 | 33,879 |  | 0 | 33879 | BEVINS M | 1 | 1 | D | MIKE B | 10-030 |  |  | 12-018F |  | 0 | 33879 | 3387900 | 100 |  |  |  |  | 10-070 | 12-035F |  |  | XX |  |  |  |  |  |  |  |  |  |  |  |  |  |  |  |  |
| 13456035 |  | Prcrmnt of Ion Pumps & Vac Valves (ARC 10/H-D Vac) |  | 62d | 2011-10-10 A | 2012-01-16 A | 13456032 | 100% |  | 2011-10-10 | 2012-01-13 |  |  |  | PROCUREMENT<$50K 60 NO ESCALATION FY11 | 105,922.9 |  | 0 | 105922.9 | BEVINS M | 1 | 1 | D | MIKE B | 10-030 | 10-065 | 11-026 | 12-018F |  | 0 | 105922.9 | 10592290 | 100 |  |  |  |  |  |  |  |  |  |  |  |  |  |  |  |  |  |  |  |  |  |  |  |  |  |
| 13456042 |  | Prcrmnt of Hall D Drift tubes (ARC 10/H-D Vac) |  | 77d | 2011-10-17 A | 2012-02-13 A | 9-120M | 100% |  |  |  |  |  |  | PROCUREMENT<$50K 60 | 37,268.62 |  | 0 | 37268.62 | BEVINS M | 1 | 1 | D | MIKE B | 10-030 |  | 11-026 |  | C | 0 | 37268.62 | 3726862 | 100 |  |  |  |  |  |  |  |  |  |  |  | 11-057 |  |  |  |  |  |  |  |  |  |  |  |  |  |
| 13456047 |  | Assemble Quad Girders for Arc10 & Hall D (ARC 10/H-D Vac) |  | 249d | 2011-12-12 A | 2013-02-11 A | 13453030 FS-3d, 13455030, 13455010, 13452050a, 13455023, 13452045 FS-150d, 13452050, 13455060, 13456040 FS-50d, 13452045a FS-150d, 13452045b FS-150d, 13455015, 13455045, 13455023a, 13455020 | 100% |  | 2011-12-12 | 2012-12-11 |  |  |  | MECH TECH [290 h]; MECH DES [60 h]; PROCUREMENT<$50K 60; MECH ENG [40 h] | 21,042.3 | 18,763.24 | 0 | 20923.07 | BEVINS M | 1 | 1 | U | MIKE B | 10-030 |  | 11-026 | 12-018F |  | 0 | 2340.47 | 234047 | 100 |  |  |  |  |  |  |  |  | XX |  |  |  |  |  |  |  |  |  |  |  |  |  |  |  |  |
| 13456030M |  | Delivery Complete for Dipole Chambers (ARC 10/H-D VACUUM) | milestone | 0d | 2013-01-24 A | 2013-01-24 A | 13456025, 13456028 | 100% |  | 2013-05-24 | 2013-05-24 |  |  |  |  |  |  |  | 0 | BEVINS M | 1 | 1 | M | MIKE B | 10-030 |  |  |  |  |  |  |  |  | 6 |  |  |  |  |  |  |  | XX |  |  |  |  |  |  |  |  |  |  |  |  |  |  |  |  |
| 13456050 |  | Re-Baseline Actuals Adjustment |  | 1d | 2013-08-30 A | 2013-08-30 A |  | 100% |  | 2013-09-03 | 2013-09-03 |  |  |  | PROCUREMENT>$50K 69 NO ESCALATION | 51,938.43 |  |  | 51938.43 |  |  |  |  |  |  |  |  |  |  | 0 | 51938.43 | 5193843 | 100 |  |  |  |  |  |  |  |  |  |  |  |  | ADJ |  |  |  |  |  |  |  |  |  |  |  |  |
|  | 7 | **1.3.4.5.7 LCW & INSTRUMENT AIR** |  |  |  |  |  |  |  |  |  |  |  |  |  |  |  |  |  |  |  |  |  |  |  |  |  |  |  |  |  |  |  |  |  |  |  |  |  |  |  |  |  |  |  |  |  |  |  |  |  |  |  |  |  |  |  |  |
|  | 8 | **1.3.4.5.8 INSTALLATION** |  |  | 2010-01-04 | 2013-12-03 |  |  |  |  |  |  |  |  |  |  |  |  |  |  |  |  |  |  |  |  |  |  |  |  |  |  |  |  |  |  |  |  |  |  |  |  |  |  |  |  |  |  |  |  |  |  |  |  |  |  |  |  |
| 13458010 |  | Install Stands in Arc 10 Phase 1 |  | 186d | 2010-01-04 A | 2010-09-27 A | 9-110M FS-500d, 13454035 FS-200d, 13454022LOE FS-20d, 4A-01M FS-500d, 13454030M | 100% |  |  |  |  |  |  | MECH TECH [80 h]; PROCUREMENT<$50K 60; MECH ENG [16 h]; MECH DES [20 h] | 5,737.12 | 5,297.6 | 0 | 5905.92 | BEVINS M | 1 | 1 | U | MIKE B | 10-030 | 10-065 |  |  |  | 0 | 439.52 | 43952 | 100 |  |  |  |  | 10-070 | 12-035F | 08-029 |  |  |  | Install |  |  |  |  |  |  |  |  |  |  |  |  |  |  |
| 13458030 |  | Remove North Stub dump & Steel (ARC 10/H-D Installtn) |  | 7d | 2010-07-01 A | 2010-07-12 A | 4A-01M | 100% |  |  |  |  |  |  |  |  |  |  | 0 | BEVINS M | 1 | 1 | Z | MIKE B | 10-030 |  |  |  |  |  |  |  |  |  |  |  |  |  |  | 08-029 | 09-012 |  |  | Install | 11-057 |  | 08-052 |  |  |  |  |  |  |  |  |  |  |  |
| 13458012 |  | Install Stands in Arc 10 Phase 2 |  | 196d | 2010-09-02 A | 2011-06-20 A | 4A-01M FS-150d, 13455125 FS-150d, 13454035 FS-130d, 13454030M | 100% |  |  |  |  |  |  | MECH DES [60 h]; MECH ENG [44 h]; MECH TECH [232 h] | 15,733.1 | 15,733.1 | 0 | 15782.84 | BEVINS M | 1 | 1 | U | MIKE B | 10-030 | 10-065 |  |  |  |  |  |  |  |  |  |  |  | 10-070 | 12-035F |  |  |  |  |  |  |  |  |  |  |  |  |  |  |  |  |  |  |  |
| 13458040 |  | Arc 10 Installation Completion |  | 149d | 2012-07-09 A | 2013-08-14 A | 9-130M FS-50d | 100% |  | 2012-07-09 | 2013-02-14 |  |  |  | MECH TECH [688 h]; MECH ENG [156 h] | 42,314.62 | 42,555.27 | 5354.98 | 42839.84 | BEVINS M | 1 | 1 | S | MIKE B | 10-030 | 10-065 |  | 12-018F |  |  |  |  |  |  |  |  |  | 10-070 | 12-035 | 08-029 | 09-012 | XX | 08-051 |  |  |  |  | 08-016 | ST | 10-059 | X |  |  |  |  |  |  |  |
| 13458050 |  | Hall D - Green door install |  | 110d | 2012-07-09 A | 2012-12-17 A | 9-130M FS-50d | 100% |  | 2012-07-09 | 2012-12-12 |  |  |  | MECH ENG [68 h]; MECH TECH [304 h] | 18,548.68 | 18,557 | 0 | 18861.92 | BEVINS M | 1 | 1 | H | MIKE B |  | 10-065 |  |  |  |  |  |  |  |  |  |  |  |  | 12-035 |  |  |  |  |  |  |  |  |  |  |  |  | 13458050 |  |  |  |  |  |  |
| 13458055 |  | Hall D - Install Stands |  | 100d | 2012-10-01 A | 2013-08-30 A | 13455085LOE, 13454032, 13455110M FS-60d, 3A-12M, 9-130M | 100% |  | 2012-10-01 | 2013-03-01 |  |  |  | MECH TECH [488 h]; MECH ENG [108 h] | 30,194.56 | 30,194.56 | 1509.728 | 30194.56 | BEVINS M | 1 | 1 | S | MIKE B |  | 10-065 |  |  |  |  |  |  |  |  |  |  |  |  | 12-035 |  |  |  |  |  |  |  |  |  | ST |  |  |  |  |  |  |  |  |  |
| 13458060 |  | Hall D - Install magnets and girders |  | 46d | 2013-05-06 A | 2013-08-30 A | 13458055 FS-20d, 13456047 | 100% |  | 2013-06-24 | 2013-08-27 |  |  |  | MECH TECH [928 h]; MECH ENG [208 h] | 57,608.96 | 57,608.96 | 5760.89599999 | 57608.96 | BEVINS M | 1 | 1 | S | MIKE B |  | 10-065 |  |  |  |  |  |  |  |  |  |  |  |  | 12-035 |  |  |  |  |  |  |  |  |  | ST |  |  |  |  |  |  |  |  |  |
| 13458045 |  | Hall D - Tagger dump installation |  | 32d | 2013-08-30 A | 2013-08-30 A | 2-16M, 9-130M FS+123d, 16331032, 2-17M, 16331030 | 100% |  | 2013-09-03 | 2013-10-16 |  |  |  | MECH ENG [176 h]; MECH TECH [784 h] | 49,271.3 | 48,689.6 | 48689.6 | 48689.6 | BEVINS M | 1 | 1 | H | MIKE B | 10-030 | 10-065 |  |  |  |  |  |  |  |  |  |  |  |  | 12-035 | 08-029 |  |  |  |  |  |  |  |  |  | 10-059 |  | 13458045 |  |  |  |  |  |  |
| 13458065 |  | Hall D - Final align |  | 5d | 2013-08-30 A | 2013-08-30 A | 13458060 | 100% |  | 2013-09-30 | 2013-10-04 |  |  |  |  |  |  |  | 0 | BEVINS M | 1 | 1 | H | MIKE B |  | 10-065 |  |  |  |  |  |  |  |  |  |  |  |  | 12-035 |  |  |  |  |  |  |  |  |  |  |  |  |  |  |  |  |  |  |  |
| 13458070 |  | Re-Baseline Actuals Adjustment |  | 1d | 2013-08-30 A | 2013-08-30 A |  | 100% |  | 2013-09-03 | 2013-09-03 |  |  |  | PROCUREMENT>$50K 69 NO ESCALATION | 131,684.5 |  |  | 131684.5 |  |  |  |  |  |  |  |  |  |  | 0 | 131684.5 | 13168450 | 100 |  |  |  |  |  |  |  |  |  |  |  |  | ADJ |  |  |  |  |  |  |  |  |  |  |  |  |
| 23458040 |  | Arc 10 Installation Completion FY13 |  | 30d | 2013-09-03 A | 2013-11-14 | 9-130M FS+228d | 60% | 10d | 2013-10-01 | 2013-11-11 | 58d | 10d | 8/5 M-F w/JLAB Holidays ReBaseline | MECH ENG [101.33 h]; MECH TECH [304 h] | 21,951.66 | 14,182.5 |  | 2127.374505 | BEVINS M | 1 | 1 | S | MIKE B | 10-030 | 10-065 |  | 12-018F |  |  |  |  |  |  |  |  |  | 10-070 | 12-035 | 08-029 | 09-012 |  | 08-051 |  |  |  |  | 08-016 | ST | 10-059 |  |  | 23458040 | 10636.872525 | PE | 13-015 | PR |  |
| 23458040a |  | Arc 10 Installation Completion FY14 |  | 10d | 2013-09-03 A | 2013-11-14 | 23458040 FS-20d | 60% | 10d | 2013-10-01 | 2013-10-14 | 58d | 20d | 8/5 M-F w/JLAB Holidays ReBaseline | MECH ENG [50.67 h]; MECH TECH [152 h] | 10,976.1 | 7,091.42 |  | 1097.6100525 | BEVINS M | 1 | 1 | S | MIKE B | 10-030 | 10-065 |  | 12-018F |  |  |  |  |  |  |  |  |  | 10-070 | 12-035 | 08-029 | 09-012 |  | 08-051 |  |  |  |  | 08-016 | ST | 10-059 |  |  | 23458040 | 5488.0502625 | PE | 13-015 | PR | 14-001 |
| 23458060 |  | Hall D - Install magnets and girders FY13 |  | 23d | 2013-09-03 A | 2013-11-27 | 9-130M FS+228d | 60% | 19d | 2013-10-01 | 2013-10-31 | 61d | 11d | 8/5 M-F w/JLAB Holidays ReBaseline | MECH TECH [98.71 h]; MECH ENG [24.68 h] | 6,513.76 | 4,452.73 |  | 2525.05296 | BEVINS M | 1 | 1 | S | MIKE B |  | 10-065 |  |  |  |  |  |  |  |  |  |  |  |  | 12-035 |  |  |  |  |  |  |  |  |  | ST |  |  |  | 23458060 | 1262.52648 | PE | 13-015 | PR |  |
| 23458060a |  | Hall D - Install magnets and girders FY14 |  | 3d | 2013-09-03 A | 2013-11-27 | 23458060 FS-30d | 60% | 19d | 2013-10-01 | 2013-10-03 | 61d | 21d | 8/5 M-F w/JLAB Holidays ReBaseline | MECH TECH [14.81 h]; MECH ENG [3.7 h] | 977.14 | 667.97 |  | 390.85716 | BEVINS M | 1 | 1 | S | MIKE B |  | 10-065 |  |  |  |  |  |  |  |  |  |  |  |  | 12-035 |  |  |  |  |  |  |  |  |  | ST |  |  |  | 23458060 | 195.42858 | PE | 13-015 | PR | 14-001 |
| 23458065 |  | Hall D - Final align FY13 |  | 4d | 2013-10-07 A | 2013-11-06 | 23458060 FS-40d, 23458060a FS-40d | 50% | 4d | 2013-11-25 | 2013-12-02 | 40d | 16d | 8/5 M-F w/JLAB Holidays ReBaseline | MECH TECH [83.2 h]; MECH ENG [20.8 h] | 5,490.16 | 4,535.35 |  | 2660.32 | BEVINS M | 1 | 1 | H | MIKE B |  | 10-065 |  |  |  |  |  |  |  |  |  |  |  |  | 12-035 |  |  |  |  |  |  |  |  |  |  |  |  |  | 23458065 |  | PE | 13-015 | PR |  |
| 23458065a |  | Hall D - Final align FY14 |  | 1d | 2013-10-07 A | 2013-11-06 | 23458065 FS-20d, 23458060a FS-40d | 50% | 4d | 2013-12-03 | 2013-12-03 | 40d | 16d | 8/5 M-F w/JLAB Holidays ReBaseline | MECH TECH [20.8 h]; MECH ENG [5.2 h] | 1,372.54 | 1,133.84 |  | 686.27 | BEVINS M | 1 | 1 | H | MIKE B |  | 10-065 |  |  |  |  |  |  |  |  |  |  |  |  | 12-035 |  |  |  |  |  |  |  |  |  |  |  |  |  | 23458065 |  | PE | 13-015 | PR | 14-001 |
| 23458045 |  | Hall D - Tagger dump installation FY13 |  | 4d | 2013-11-01 | 2013-11-06 | 9-130M FS+244d |  |  |  |  | 63d | 0d | 8/5 M-F w/JLAB Holidays ReBaseline | MECH ENG [38.48 h]; MECH TECH [153.9 h] | 10,155.74 |  |  | 0 | BEVINS M | 1 | 1 | S | MIKE B | 10-030 | 10-065 |  |  |  |  |  |  |  |  |  |  |  |  | 12-035 | 08-029 |  |  |  |  |  |  |  |  |  | 10-059 |  |  | 23458045 |  | PE | 13-015 | PR |  |
| 23458045a |  | Hall D - Tagger dump installation FY14 |  | 17d | 2013-11-07 | 2013-12-03 | 23458045 |  |  |  |  | 63d | 26d | 8/5 M-F w/JLAB Holidays ReBaseline | MECH ENG [163.52 h]; MECH TECH [654.1 h] | 43,162.16 |  |  | 0 | BEVINS M | 1 | 1 | S | MIKE B | 10-030 | 10-065 |  |  |  |  |  |  |  |  |  |  |  |  | 12-035 | 08-029 |  |  |  |  |  |  |  |  |  | 10-059 |  |  | 23458045 |  | PE | 13-015 | PR | 14-001 |

Notes:
- 13458040: Steps: Non Tangent Point (done); N Tangent Point (done); S Tangent Point (done)
- 13458055: Steps: Mark Bolts (done); Grout Floor Plates (done); Install Pedestals Part 1 (done); Install Pedestals Part 2 (done); Install Pedestals Part 3 (done); Align Pedestals Part 1 (done); Align Pedestals Part 2 (done); Install LCW/Instrument Air Part 1 (done); Install LCW/Instrument Air Part 2 (done)
- 13458060: Steps: Install quad girders (done); Install dipoles (done); initial 2A align girders (done); initial 2A align dipoles (done); final align girders (done); final align dipoles (done)
- 23458040: Steps: Northwest vacuum reconnect (done); Southwest vacuum reconnect (done); Vacuum leakcheck (done); Dogleg stand mods; Install SRCC terminal wiring; Install Arc dipole shims
- 23458040a: Steps: Northwest vacuum reconnect (done); Southwest vacuum reconnect (done); Vacuum leakcheck (done); Dogleg stand mods; Install SRCC terminal wiring; Install Arc dipole shims
- 23458060: Steps: Install LCW mainfolds (done); Install Air manifolds (done); Install diagnostic girder (done); Align for hookup; LCW and Air hookup; Install insertable dump; Vacuum hookup; Vacuum leakcheck; Install beamline to tagger valve
- 23458060a: Steps: Install LCW mainfolds (done); Install Air manifolds (done); Install diagnostic girder (done); Align for hookup; LCW and Air hookup; Install insertable dump; Vacuum hookup; Vacuum leakcheck; Install beamline to tagger valve

| ID | WBS | Activity | Type | Duration | Start | Finish | Predecessors | Complete | Planned start | Planned finish | Calendar | Resources | Cost | Actual cost | Calculated Remaining Total Cost | MONTHLY EV COST | RESP - Responsibility | STRT%COMP for CM EVM | FNSH%COMP for CM EVM | EVMS Reporting Codes | CAM RESPONSIBLE | CR 11-028 | CR 12-029 | CR 12-035 | LOE % Pre Calc | LOE % | LOE Divider | LOE Multiplier | Remaining Material Cost Based on % Compl | Claimed Material Cost Based on % Complet | Initial Claimed Material Calc | Claimed Material Divider | CR 11-057 | MARCH!!! | ReBaseline Actuals Adjustment | Milestone Level | CR 12-001 | CR 12-039 | In Progress Procurements | Activities with Steps | CR 12-053 | Original Activity ID Rebaseline | PRIOR MONTH EV COST | BOE Labor | CR 13-015 | Post Rebaseline | CR 14-001 |
| --- | --- | --- | --- | --- | --- | --- | --- | --- | --- | --- | --- | --- | --- | --- | --- | --- | --- | --- | --- | --- | --- | --- | --- | --- | --- | --- | --- | --- | --- | --- | --- | --- | --- | --- | --- | --- | --- | --- | --- | --- | --- | --- | --- | --- | --- | --- | --- |
|  | 6 | **1.3.4.6 EXTRACTION** |  |  | 2011-04-01 | 2013-10-21 |  |  |  |  |  |  |  |  |  |  |  |  |  |  |  |  |  |  |  |  |  |  |  |  |  |  |  |  |  |  |  |  |  |  |  |  |  |  |  |  |  |
|  | 1 | **1.3.4.6.1 LAMBERTSON** |  |  | 2011-04-01 | 2013-08-30 |  |  |  |  |  |  |  |  |  |  |  |  |  |  |  |  |  |  |  |  |  |  |  |  |  |  |  |  |  |  |  |  |  |  |  |  |  |  |  |  |  |
| 13461000 |  | Proc Coil Packs for Lambertson LABOR (LAMBERTSON) |  | 100d | 2011-04-01 A | 2011-08-22 A | 12154020M | 100% |  |  |  | MECH ENG [140 h]; MECH DES [60 h] | 12,313.8 | 12,313.8 | 0 | 12707 | BEVINS M | 1 | 1 | H | MIKE B | 11-028 | 12-029F | 12-035F |  |  |  |  |  |  |  |  |  |  |  |  |  |  |  |  |  |  |  |  |  |  |  |
| 13461050LOE |  | FY11 Engrng Oversight (LAMBERTSON) |  | 128d | 2011-04-01 A | 2011-09-30 A | 9-110M FS+120d | 100% |  |  |  | MECH ENG [41.29 h]; TRAVEL | 4,561.27 | 2,805.66 | 0 | 4561.2655 | BEVINS M | 1 | 1 | E | MIKE B | 11-028 |  |  | 16.40625 | 83.59375 | 100 | 100 |  |  |  |  |  |  |  |  |  |  |  |  |  |  |  |  |  |  |  |
| 13461005 |  | Proc Coil Packs for Lambertson MATL (LAMBERTSON) |  | 22d | 2011-06-01 A | 2011-06-30 A | 13461000 FS-64d | 100% |  |  |  | PROCUREMENT<$50K 60 | 36,855.18 |  | 0 | 36855.18 | BEVINS M | 1 | 1 | D | MIKE B | 11-028 | 12-029F | 12-035F |  |  |  |  | 0 | 36855.18 | 3685518 | 100 |  |  |  |  |  |  |  |  |  |  |  |  |  |  |  |
| 13461015 |  | Machine Lambertson Mag Iron MATL (LAMBERTSON) |  | 11d | 2013-02-04 A | 2013-02-18 A | 9-130M FS+165d, 13461010 FS-30d | 100% | 2013-06-04 | 2013-06-18 |  | PROCUREMENT<$50K 60 | 7,020.05 |  | 0 | 7020.05 | BEVINS M | 1 | 1 | D | MIKE B | 11-028 | 12-029F | 12-035F |  |  |  |  | 0 | 7020.05 | 702005 | 100 | 11-057 | XX |  |  |  |  |  |  |  |  |  |  |  |  |  |
| 13461010 |  | Machine Lambertson Mag Iron LABOR (LAMBERTSON) |  | 10d | 2013-05-04 A | 2013-06-17 A | 9-130M FS+165d, 9-120M FS+220d | 100% | 2013-06-04 | 2013-06-17 |  | MECH DES [60 h]; MECH ENG [60 h] | 7,324.2 | 7,324.2 | 0 | 7097.4 | BEVINS M | 1 | 1 | H | MIKE B | 11-028 | 12-029F | 12-035F |  |  |  |  |  |  |  |  | 11-057 | XX |  |  |  |  |  |  |  |  |  |  |  |  |  |
| 13461035 |  | Install New Lambertson MATL (LAMBERTSON) |  | 5d | 2013-05-18 A | 2013-05-24 A | 13461020 FS-20d | 100% | 2013-06-18 | 2013-06-24 |  | PROCUREMENT<$50K 60 | 6,881.78 |  | 0 | 6881.78 | BEVINS M | 1 | 1 | D | MIKE B | 11-028 | 12-029F | 12-035 |  |  |  |  | 0 | 6881.78 | 688178 | 100 |  | XX |  |  |  |  |  |  |  |  |  |  |  |  |  |
| 13461025 |  | Install Lambertson Coil pack (LAMBERTSON) |  | 5d | 2013-06-10 A | 2013-07-15 A | 2-02M FS+125d, 9-130M FS+165d, 13461005, 13461015 | 100% | 2013-07-01 | 2013-07-08 |  | MECH TECH [120 h]; MECH ENG [40 h]; MECH DES [40 h] | 10,386 | 10,386 | 0 | 10386 | BEVINS M | 1 | 1 | H | MIKE B | 11-028 | 12-029F | 12-035 |  |  |  |  |  |  |  |  |  | XX |  |  |  |  |  |  |  |  |  |  |  |  |  |
| 13461040 |  | Test New Lambertson (LAMBERTSON) |  | 5d | 2013-06-10 A | 2013-08-30 A | 13461035 FS-20d | 100% | 2013-07-16 | 2013-07-22 |  | ELEC TECH [20 h] | 910.8 | 910.8 | 455.4 | 910.8 | BEVINS M | 1 | 1 | H | MIKE B | 11-028 | 12-029F | 12-035 |  |  |  |  |  |  |  |  |  | XX |  |  |  |  |  |  |  |  |  |  |  |  |  |
| 13461020 |  | Lambertson Mag measurements (LAMBERTSON) |  | 5d | 2013-08-30 A | 2013-08-30 A | 13461025, 9-130M FS+165d | 100% | 2013-09-03 | 2013-09-09 |  | MECH TECH [40 h]; MECH ENG [20 h] | 3,281.6 | 3,281.6 | 3281.6 | 3281.6 | BEVINS M | 1 | 1 | H | MIKE B | 11-028 | 12-029F | 12-035 |  |  |  |  |  |  |  |  |  | XX |  |  |  |  |  |  |  |  |  |  |  |  |  |
| 13461055 |  | Re-Baseline Actuals Adjustment |  | 1d | 2013-08-30 A | 2013-08-30 A |  | 100% | 2013-09-03 | 2013-09-03 |  | PROCUREMENT>$50K 69 NO ESCALATION | -67,098.24 |  |  |  |  |  |  |  |  |  |  |  |  |  |  |  |  |  |  | 100 |  |  | ADJ |  |  |  |  |  |  |  |  |  |  |  |  |
| 13461045M |  | Ready for Beam Commssng (LAMBERTSON) | milestone | 0d | 2013-08-30 A | 2013-08-30 A | 13461040 | 100% | 2013-09-09 | 2013-09-09 |  |  |  |  |  | 0 | BEVINS M | 1 | 1 | M | MIKE B | 11-028 | 12-029F | 12-035 |  |  |  |  |  |  |  |  |  | XX |  | 6 |  |  |  |  |  |  |  |  |  |  |  |
|  | 2 | **1.3.4.6.2 CHICANE** |  |  | 2011-04-01 | 2013-08-30 |  |  |  |  |  |  |  |  |  |  |  |  |  |  |  |  |  |  |  |  |  |  |  |  |  |  |  |  |  |  |  |  |  |  |  |  |  |  |  |  |  |
| 13462000 |  | Fab Dipole Magnets (CHICANE) Original Labor FY11 |  | 211d | 2011-04-01 A | 2012-02-08 A | 1355040a | 100% | 2011-04-01 | 2012-02-07 |  | MECH ENG [75.94 h]; MECH DES [31.06 h] | 6,693.04 | 6,708.11 | 0 | 6610.0038 | BEVINS M | 1 | 1 | E | MIKE B | 11-028 |  | 12-035F | 5.46875 | 94.53125 | 100 | 100 |  |  |  |  |  |  |  |  | 12-001 |  |  |  |  |  |  |  |  |  |  |
| 13462000a |  | Fab Dipole Magnets (CHICANE) Original Labor FY12 |  | 212d | 2011-04-01 A | 2012-02-08 A | 13462000 FS-90d | 100% |  |  |  | MECH ENG [49.83 h]; MECH DES [20.39 h] | 4,392.63 | 4,392.63 | 0 | 4476.2659 | BEVINS M | 1 | 1 | E | MIKE B | 11-028 |  | 12-035F | 8.33333333 | 91.66666666 | 100 | 100 |  |  |  |  |  |  |  |  | 12-001 |  |  |  |  |  |  |  |  |  |  |
| 13462015LOE |  | FY11 Mech Eng/Dsgner Oversight (CHICANE) |  | 128d | 2011-04-01 A | 2011-09-30 A | 9-110M FS+120d | 100% |  |  |  | TRAVEL | 2,340.81 |  | 0 | 2340.81 | BEVINS M | 1 | 1 | E | MIKE B | 11-028 |  |  | 16.40625 | 83.59375 | 100 | 100 |  |  |  |  |  |  |  |  |  |  |  |  |  |  |  |  |  |  |  |
| 13462005 |  | Measure Dipole Magnets (CHICANE) |  | 200d | 2012-03-06 A | 2013-03-11 A | 13411105t, 13411105u, 13462000a FS+40d | 100% | 2012-03-06 | 2012-12-17 |  | MECH ENG [40 h]; MECH TECH [80 h] | 6,414.86 | 6,445.47 | 0 | 6360 | BEVINS M | 1 | 1 | H | MIKE B | 11-028 |  | 12-035F |  |  |  |  |  |  |  |  |  | XX |  |  |  |  |  |  |  |  |  |  |  |  |  |
| 13462010M |  | Extraction Dipoles Ready for Installtn (CHICANE) | milestone | 0d | 2013-03-11 A | 2013-03-11 A | 13462005 | 100% | 2013-04-15 | 2013-04-15 |  |  |  |  |  | 0 | BEVINS M | 1 | 1 | M | MIKE B | 11-028 |  | 12-035F |  |  |  |  |  |  |  |  |  | XX |  | 6 |  |  |  |  |  |  |  |  |  |  |  |
| 13462020 |  | Re-Baseline Actuals Adjustment |  | 1d | 2013-08-30 A | 2013-08-30 A |  | 100% | 2013-09-03 | 2013-09-03 |  | PROCUREMENT>$50K 69 NO ESCALATION | -9,920.24 |  |  |  |  |  |  |  |  |  |  |  |  |  |  |  |  |  |  | 100 |  |  | ADJ |  |  |  |  |  |  |  |  |  |  |  |  |
|  | 3 | **1.3.4.6.3 STANDS** |  |  | 2011-12-05 | 2013-10-21 |  |  |  |  |  |  |  |  |  |  |  |  |  |  |  |  |  |  |  |  |  |  |  |  |  |  |  |  |  |  |  |  |  |  |  |  |  |  |  |  |  |
| 13463005 |  | Fab Stands LABOR (Stands) |  | 11d | 2011-12-05 A | 2011-12-19 A | 13463000 FS-125d | 100% |  |  |  | MECH DES [4 h]; MECH ENG [4 h] | 473.16 | 473.16 | 0 | 473.16 | BEVINS M | 1 | 1 | H | MIKE B | 11-028 |  | 12-035F |  |  |  |  |  |  |  |  |  |  |  |  |  |  |  |  |  |  |  |  |  |  |  |
| 13463010 |  | Fab Stands MATL (Stands) Frozen Per CR12-039 |  | 84d | 2012-01-03 A | 2012-05-01 A | 13463005 FS-86d | 100% |  |  |  | PROCUREMENT<$50K 60 | 16,907.95 |  | 0 | 16907.95 | BEVINS M | 1 | 1 | H | MIKE B | 11-028 |  | 12-035F |  |  |  |  | 0 | 16907.95 | 1690795 | 100 |  |  |  |  |  | 12-039 |  |  |  |  |  |  |  |  |  |
| 13463045LOE |  | FY12 Mech Eng/Dsgner Oversight (Stands) |  | 189d | 2012-01-03 A | 2012-09-28 A | 9-120M FS+60d | 100% |  |  |  | TRAVEL | 1,207.76 |  | 0 | 1207.76 | BEVINS M | 1 | 1 | E | MIKE B | 11-028 |  |  | 10.05291005 | 89.94708994 | 100 | 100 |  |  |  |  |  |  |  |  |  |  |  |  |  |  |  |  |  |  |  |
| 13463012 |  | Reverse Entry Per CR12-039 |  | 3d | 2012-05-01 A | 2012-05-03 A | 9-120M FS+141d | 100% |  |  |  | PROCUREMENT<$50K 60 | -16,907.95 |  |  |  | BEVINS M | 1 | 1 | H | MIKE B | 11-028 |  | 12-035F |  |  |  |  |  |  |  | 100 |  |  |  |  |  | 12-039 |  |  |  |  |  |  |  |  |  |
| 13463013 |  | Fab Stands MATL (Stands) Revised Per CR12-039 |  | 169d | 2012-05-01 A | 2013-07-15 A | 13463005 FS-3d | 100% | 2012-05-01 | 2013-01-07 |  | PROCUREMENT<$50K 60 | 15,926.29 |  | 0 | 15926.29 | BEVINS M | 1 | 1 | D | MIKE B | 11-028 |  | 12-035F |  |  |  |  | 0 | 15926.29 | 1592629 | 100 |  | XX |  |  |  | 12-039 | Split |  |  |  |  |  |  |  |  |
| 13463000 |  | Insp Matls (Stands) |  | 13d | 2012-05-11 A | 2012-05-30 A | 1356018 FS-100d, 9-120M, 1356020 FS-150d | 100% |  |  |  | MECH TECH [18 h]; MECH ENG [5.4 h] | 1,178.57 | 1,178.57 | 0 | 1178.568 | BEVINS M | 1 | 1 | H | MIKE B | 11-028 |  | 12-035F |  |  |  |  |  |  |  |  |  |  |  |  |  |  |  |  |  |  |  |  |  |  |  |
| 13463015 |  | Extraction - Remove |  | 104d | 2012-05-18 A | 2012-10-15 A | 2-02M, 13463013 FS-20d, 13463010 | 100% |  |  |  | MECH TECH [792 h]; MECH ENG [572 h] | 75,559.59 | 75,559.59 | 0 | 75305.12 | BEVINS M | 1 | 1 | H | MIKE B | 11-028 |  | 12-035 |  |  |  |  |  |  |  |  |  |  |  |  |  |  |  |  |  |  |  |  |  |  |  |
| 13463035 |  | Extraction - Upstairs FY12 |  | 59d | 2012-10-01 A | 2013-08-27 A | 13463015 FS-20d | 100% | 2012-10-01 | 2012-12-31 |  | MECH TECH [445.41 h]; MECH ENG [220.54 h] | 36,384.77 | 36,384.77 | 705.16570399 | 35258.2852 | BEVINS M | 1 | 1 | S | MIKE B | 11-028 |  | 12-035 |  |  |  |  |  |  |  |  |  | XX |  |  |  |  |  | ST | 12-053 |  |  |  |  |  |  |
| 13463035a |  | Extraction - Upstairs FY13 |  | 59d | 2012-10-01 A | 2013-08-27 A | 13463035 FS-60d | 100% | 2012-10-01 | 2012-12-31 |  | MECH TECH [378.59 h]; MECH ENG [187.46 h] | 30,926.75 | 30,926.75 | 618.53486 | 30926.743 | BEVINS M | 1 | 1 | S | MIKE B | 11-028 |  | 12-035 |  |  |  |  |  |  |  |  |  | XX |  |  |  |  |  | ST | 12-053 |  |  |  |  |  |  |
| 13463025 |  | Extraction - Install stands |  | 35d | 2012-11-12 A | 2013-02-11 A | 13462010M FS-20d, 1355025M, 13463015, 13463020 FS-30d | 100% | 2012-11-12 | 2013-01-09 |  | MECH ENG [100 h]; MECH TECH [448 h] | 27,781.28 | 27,781.28 | 0 | 27781.28 | BEVINS M | 1 | 1 | H | MIKE B | 11-028 |  | 12-035 |  |  |  |  |  |  |  |  |  | XX |  |  |  |  |  |  |  |  |  |  |  |  |  |
| 13463020 |  | Install Stands MATL (Stands) |  | 22d | 2012-12-03 A | 2013-08-30 A | 13463015 FS+33d | 100% | 2013-01-02 | 2013-02-01 |  | PROCUREMENT<$50K 60 | 4,708.58 |  | 2354.29 | 4708.58 | BEVINS M | 1 | 1 | H | MIKE B | 11-028 |  | 12-035 |  |  |  |  | 0 | 4708.58 | 470858 | 100 |  | XX |  |  |  |  |  |  |  |  |  |  |  |  |  |
| 13463030 |  | Install Septa & Dipoles MATL (Stands) |  | 43d | 2013-04-01 A | 2013-06-17 A | 13463025 | 100% | 2013-05-01 | 2013-07-01 |  | PROCUREMENT<$50K 60 | 10,262.31 |  | 0 | 10262.31 | BEVINS M | 1 | 1 | H | MIKE B | 11-028 |  | 12-035 |  |  |  |  | 0 | 10262.31 | 1026231 | 100 |  |  |  |  |  |  |  |  |  |  |  |  |  |  |  |
| 13463045 |  | Extraction - Install magnets and girders |  | 43d | 2013-07-15 A | 2013-08-30 A | 13463025, 13463020 FS-20d, 13463035a FS-20d | 100% | 2013-08-28 | 2013-10-28 |  | MECH TECH [1096 h]; MECH ENG [244 h] | 68,924.82 | 67,918.4 | 20375.52 | 67918.4 | BEVINS M | 1 | 1 | S | MIKE B | 11-028 |  | 12-035 |  |  |  |  |  |  |  |  |  |  |  |  |  |  |  | ST |  |  |  |  |  |  |  |
| 13463050 |  | Extraction - Final align |  | 6d | 2013-08-30 A | 2013-08-30 A | 13417120, 13463030, 13463045 | 100% | 2013-11-01 | 2013-11-08 |  | MECH TECH [240 h]; MECH ENG [52 h] | 15,239.64 | 14,769.12 | 14769.12 | 14769.12 | BEVINS M | 1 | 1 | H | MIKE B | 11-028 |  | 12-035 |  |  |  |  |  |  |  |  |  |  |  |  |  |  |  |  |  |  |  |  |  |  |  |
| 13463055 |  | Re-Baseline Actuals Adjustment |  | 1d | 2013-08-30 A | 2013-08-30 A |  | 100% | 2013-09-03 | 2013-09-03 |  | PROCUREMENT>$50K 69 NO ESCALATION | 256,305.09 |  |  | 256305.09 |  |  |  |  |  |  |  |  |  |  |  |  | 0 | 256305.09 | 25630509 | 100 |  |  | ADJ |  |  |  |  |  |  |  |  |  |  |  |  |
| 23463035a |  | Extraction - Upstairs |  | 6d | 2013-09-03 A | 2013-09-23 A | 9-130M FS+228d | 100% | 2013-10-01 | 2013-10-08 | 8/5 M-F w/JLAB Holidays ReBaseline | MECH TECH [29.44 h]; MECH ENG [7.36 h] | 1,942.67 | 1,882.69 |  | 0 | BEVINS M | 1 | 1 | H | MIKE B | 11-028 |  | 12-035 |  |  |  |  |  |  |  |  |  |  |  |  |  |  |  |  | 12-053 | 23463035a | 1882.688 | PE | 13-015 | PR |  |
| 23463045 |  | Extraction - Install magnets and girders |  | 15d | 2013-09-03 A | 2013-10-21 A | 23463035a FS-48d, 9-130M FS+228d | 100% | 2013-10-01 | 2013-10-21 | 8/5 M-F w/JLAB Holidays ReBaseline | MECH TECH [436.54 h]; MECH ENG [104.12 h] | 28,431.69 | 28,128.98 |  | 4133.07407925 | BEVINS M | 1 | 1 | S | MIKE B | 11-028 |  | 12-035 |  |  |  |  |  |  |  |  |  |  |  |  |  |  |  | ST |  | 23463045 | 23420.75311575 | PE | 13-015 | PR |  |
| 23463050 |  | Extraction - Final align FY13 |  | 12d | 2013-09-16 A | 2013-10-21 A | 23463045 FS-15d, 23417120 FS-23d | 100% | 2013-10-22 | 2013-11-06 | 8/5 M-F w/JLAB Holidays ReBaseline | MECH TECH [100 h]; MECH ENG [25 h] | 6,598.75 | 6,559.15 |  | 1598.75 | BEVINS M | 1 | 1 | S | MIKE B | 11-028 |  | 12-035 |  |  |  |  |  |  |  |  |  |  |  |  |  |  |  | ST |  | 23463050 | 4796.25 | PE | 13-015 | PR |  |
| 23463050a |  | Extraction - Final align FY14 |  | 7d | 2013-09-16 A | 2013-10-21 A | 23463050 FS-20d | 100% | 2013-10-01 | 2013-10-09 | 8/5 M-F w/JLAB Holidays ReBaseline | MECH TECH [140 h]; MECH ENG [35 h] | 9,238.25 | 9,170.04 |  | 2309.5625 | BEVINS M | 1 | 1 | S | MIKE B | 11-028 |  | 12-035 |  |  |  |  |  |  |  |  |  |  |  |  |  |  |  | ST |  | 23463050 | 6928.6875 | PE | 13-015 | PR | 14-001 |

Notes:
- 13462005: Explanation: IPL from 6 GeV 534213060 and / 534213120
- 13463035: Steps: Disassemble Dipoles Part 1 (done); Disassemble Dipoles Part 2 (done); Disassemble Septa Part 1 (done); Disassemble Septa Part 2 (done); Reassemble Dipoles Part 1 (done); Reassemble Dipoles Part 2 (done); Reassemble Septa Part 1 (done); Reassemble Septa Part 2 (done); Machine Dipoles Part 1 (done); Machine Dipoles Part 2 (done); Measure Dipoles Part 1 (done); Measure Dipoles Part 2 (done); Measure Septa Part 1 (done); Measure Septa Part 2 (done); Rebuild Girders Part 1 (done); Rebuild Girders Part 2 (done)
- 13463035a: Steps: Disassemble Dipoles Part 1 (done); Disassemble Dipoles Part 2 (done); Disassemble Septa Part 1 (done); Disassemble Septa Part 2 (done); Reassemble Dipoles Part 1 (done); Reassemble Dipoles Part 2 (done); Reassemble Septa Part 1 (done); Reassemble Septa Part 2 (done); Machine Dipoles Part 1 (done); Machine Dipoles Part 2 (done); Measure Dipoles Part 1 (done); Measure Dipoles Part 2 (done); Measure Septa Part 1 (done); Measure Septa Part 2 (done); Rebuild Girders Part 1 (done); Rebuild Girders Part 2 (done)
- 13463045: Steps: Install septa (done); install dipoles (done); install LCW (done); Install RF sep (done); install girders (done); install vac and leakcheck (done)
- 23463045: Steps: Install LCW & Air manifolds (done); Install RF sep (done); Rebuild E03 girders (done); Complete installation of E03 girders (done); Align E03 girders (done); LCW hookup & hose fab (done); Beampipe fabrication (done); Vacuum hookup (done)
- 23463050: Steps: Align septa, dipoles and girders (done); Align beampipes (done)
- 23463050a: Steps: Align septa, dipoles and girders (done); Align beampipes (done)

| ID | WBS | Activity | Duration | Start | Finish | Predecessors | Complete | Planned start | Planned finish | Resources | Cost | Actual cost | LOE Divider | LOE Multiplier | Calculated Remaining Total Cost | MONTHLY EV COST | RESP - Responsibility | STRT%COMP for CM EVM | FNSH%COMP for CM EVM | EVMS Reporting Codes | CAM RESPONSIBLE | CR 08-058 | CR 11-028 | LOE % Pre Calc | LOE % | MARCH!!! | Remaining Material Cost Based on % Compl | Claimed Material Cost Based on % Complet | Initial Claimed Material Calc | Claimed Material Divider | In Progress Procurements | OPC Allison | Installation | CR 12-053 | ReBaseline Actuals Adjustment |
| --- | --- | --- | --- | --- | --- | --- | --- | --- | --- | --- | --- | --- | --- | --- | --- | --- | --- | --- | --- | --- | --- | --- | --- | --- | --- | --- | --- | --- | --- | --- | --- | --- | --- | --- | --- |
|  | 4 | **1.3.4.6.4 NOT USED** |  |  |  |  |  |  |  |  |  |  |  |  |  |  |  |  |  |  |  |  |  |  |  |  |  |  |  |  |  |  |  |  |  |
|  | 5 | **1.3.4.6.5 NOT USED** |  |  |  |  |  |  |  |  |  |  |  |  |  |  |  |  |  |  |  |  |  |  |  |  |  |  |  |  |  |  |  |  |  |
|  | 6 | **1.3.4.6.6 NOT USED** |  |  |  |  |  |  |  |  |  |  |  |  |  |  |  |  |  |  |  |  |  |  |  |  |  |  |  |  |  |  |  |  |  |
|  | 7 | **1.3.4.6.7 NOT USED** |  |  |  |  |  |  |  |  |  |  |  |  |  |  |  |  |  |  |  |  |  |  |  |  |  |  |  |  |  |  |  |  |  |
|  | 5 | **1.3.5 EXTRACTION** |  | 2009-01-02 | 2013-08-30 |  |  |  |  |  |  |  |  |  |  |  |  |  |  |  |  |  |  |  |  |  |  |  |  |  |  |  |  |  |  |
|  | 1 | **1.3.5.1 CAVITIES** |  | 2009-01-02 | 2013-08-30 |  |  |  |  |  |  |  |  |  |  |  |  |  |  |  |  |  |  |  |  |  |  |  |  |  |  |  |  |  |  |
| 1351909LOE |  | FY09 Mngmnt Oversight (Cavities) | 189d | 2009-01-02 A | 2009-09-30 A | 1351909LOEX | 100% |  |  | TRAVEL; SCIENTIST [423.73 h] | 30,069.12 | 27,228.89 | 100 | 100 | 0 | 30069.122317 | SPATA M | 1 | 1 | E | MIKE S | 08-058 |  |  |  |  |  |  |  |  |  |  |  |  |  |
| 1351910LOE |  | FY10 Mngmnt Oversight (Cavities) | 248d | 2009-10-01 A | 2010-09-30 A | 1351909LOE | 100% |  |  | SCIENTIST [556 h]; TRAVEL | 40,714.11 | 36,868.36 | 100 | 100 | 0 | 40714.106834 | SPATA M | 1 | 1 | E | MIKE S |  |  |  |  |  |  |  |  |  |  |  |  |  |  |
| 1351018 |  | Fab fixturing Assys for Fab (Cavities) | 13d | 2010-10-01 A | 2010-10-19 A | 9-110M | 100% |  |  | MECH TECH [20 h] | 861.4 | 861.4 |  |  | 0 | 861.4 | SPATA M | 1 | 1 | H | MIKE S |  | 11-028 |  |  |  |  |  |  |  |  |  |  |  |  |
| 1351911LOE |  | FY11 Mngmnt Oversight (Cavities) | 248d | 2010-10-01 A | 2011-09-30 A | 1351910LOE | 100% |  |  | SCIENTIST [440 h] | 30,109.2 | 30,109.2 | 100 | 100 | 0 | 30109.2 | SPATA M | 1 | 1 | E | MIKE S |  |  | 8.46774193 | 91.53225806 |  |  |  |  |  |  |  |  |  |  |
| 1351016 |  | Proc Separator Cavity Matls & subassemblies LABOR (Cavities) | 286d | 2011-11-01 A | 2013-05-13 A | 9-120M FS+41d, 12151020M | 100% | 2011-11-01 | 2013-01-02 | MECH ENG [48 h]; MECH TECH [20 h] | 4,283.08 | 4,309.01 |  |  | 0 | 4254.56 | SPATA M | 1 | 1 | D | MIKE S |  | 11-028 |  |  | XX |  |  |  |  |  |  |  |  |  |
| 1351016a |  | Proc Separator Cavity Matls & subassemblies MATERIALS (Cavities) | 229d | 2012-02-01 A | 2013-07-15 A | 1351016 FS-115d | 100% | 2012-02-01 | 2013-01-02 | PROCUREMENT<$50K 60 | 62,010.32 |  |  |  | 1240.2064 | 62010.32 | SPATA M | 1 | 1 | D | MIKE S |  | 11-028 |  |  | XX | 0 | 62010.32 | 6201032 | 100 | Split |  |  |  |  |
| 1351040 |  | Assy of Separator Cavities (Cavities) | 50d | 2013-01-14 A | 2013-07-16 A | 1351018, 1351016a FS-40d | 100% | 2013-03-20 | 2013-05-29 | MECH ENG [20 h]; MECH TECH [128 h]; PROCUREMENT<$50K 60 | 12,605.71 | 7,317.28 |  |  | 6189.575 | 12379.15 | SPATA M | 1 | 1 | H | MIKE S |  | 11-028 |  |  |  | 0 | 5288.43 | 528843 | 100 |  | OPC A |  |  |  |
| 1351055 |  | Test Separator Cavities | 45d | 2013-06-10 A | 2013-08-23 A | 1351040 FS-20d | 100% | 2013-07-18 | 2013-09-19 | ELEC ENG [40 h]; ELEC TECH [40 h]; MECH TECH [32 h] | 6,201.52 | 6,201.52 |  |  | 3004.84 | 6009.68 | SPATA M | 1 | 1 | H | MIKE S |  | 11-028 |  |  |  |  |  |  |  |  | OPC A |  |  |  |
| 1351080 |  | RF Characterization of Installed Separator Cavities (Cavities) | 10d | 2013-06-10 A | 2013-08-23 A | 1351065a FS-60d, 1351065 FS-60d | 100% | 2013-09-27 | 2013-10-10 | MECH ENG [12 h]; ELEC TECH [60 h]; ELEC ENG [60 h] | 8,172.46 | 7,969.32 |  |  | 3984.66 | 7969.32 | SPATA M | 1 | 1 | H | MIKE S |  | 11-028 |  |  |  |  |  |  |  |  | OPC A |  |  |  |
| 1351065 |  | Installtn of Separator Cavities (Cavities) FY12 | 17d | 2013-07-15 A | 2013-08-23 A | 1351055 FS-20d, 2-02M | 100% | 2013-09-24 | 2013-10-16 | MECH DES [27.2 h]; ELEC ENG [13.6 h]; MECH TECH [68 h]; ELEC TECH [68 h] | 8,750.01 | 8,557.53 |  |  | 8292.6 | 8292.6 | SPATA M | 1 | 1 | H | MIKE S |  | 11-028 |  |  |  |  |  |  |  |  | OPC A | Install | 12-053 |  |
| 1351065a |  | Installtn of Separator Cavities (Cavities) FY13 | 8d | 2013-07-15 A | 2013-08-23 A | 1351065 FS-400d | 100% | 2013-10-17 | 2013-10-28 | ELEC TECH [32 h]; ELEC ENG [6.4 h]; MECH DES [12.8 h]; MECH TECH [32 h] | 4,155.39 | 4,027.07 |  |  | 4027.072 | 4027.072 | SPATA M | 1 | 1 | H | MIKE S |  | 11-028 |  |  |  |  |  |  |  |  |  |  | 12-053 |  |
| 1351950 |  | Re-Baseline Actuals Adjustment | 1d | 2013-08-30 A | 2013-08-30 A |  | 100% | 2013-09-03 | 2013-09-03 | PROCUREMENT>$50K 69 NO ESCALATION | 88,708.49 |  |  |  |  | 88708.49 |  |  |  |  |  |  |  |  |  |  | 0 | 88708.49 | 8870849 | 100 |  |  |  |  | ADJ |
|  | 2 | **1.3.5.2 RF COMPONENTS** |  | 2012-03-02 | 2013-08-30 |  |  |  |  |  |  |  |  |  |  |  |  |  |  |  |  |  |  |  |  |  |  |  |  |  |  |  |  |  |  |
| 1352005 |  | Proc RF Components LABOR (RF Compnts) | 209d | 2012-03-02 A | 2012-12-17 A | 9-120M FS+60d, 12156045, 12152030M | 100% | 2012-03-02 | 2013-01-03 | ELEC DES [80 h]; ELEC ENG [40 h] | 6,927.06 | 6,921.69 |  |  | 0 | 6863.2 | SPATA M | 1 | 1 | H | MIKE S |  | 11-028 |  |  |  |  |  |  |  |  |  |  |  |  |
| 1352005a |  | Proc RF Components MATERIAL (RF Compnts) | 188d | 2012-04-09 A | 2013-03-11 A | 1352005 FS-20d | 100% | 2012-04-09 | 2013-01-10 | PROCUREMENT<$50K 60 | 104,130.53 |  |  |  | 0 | 104130.53 | SPATA M | 1 | 1 | D | MIKE S |  | 11-028 |  |  | XX | 0 | 104130.53 | 10413053 | 100 |  |  |  |  |  |
| 1352020 |  | Install RF Components (RF Compnts) | 46d | 2013-01-07 A | 2013-08-19 A | 2-02M, 1352005a FS-20d | 100% | 2013-02-14 | 2013-04-19 | MECH TECH [116 h]; ELEC TECH [400 h] | 23,535.76 | 23,535.76 |  |  | 11403.52 | 22807.04 | SPATA M | 1 | 1 | H | MIKE S |  | 11-028 |  |  |  |  |  |  |  |  | OPC A | Install |  |  |
| 1352035 |  | Characterize Sys losses (RF Compnts) | 39d | 2013-05-06 A | 2013-06-17 A | 1352020 FS-20d | 100% | 2013-07-23 | 2013-09-16 | ELEC TECH [200 h]; ELEC ENG [80 h] | 14,932.8 | 14,932.8 |  |  | 0 | 14470.8 | SPATA M | 1 | 1 | H | MIKE S |  | 11-028 |  |  |  |  |  |  |  |  | OPC A |  |  |  |
| 1352040 |  | Re-Baseline Actuals Adjustment | 1d | 2013-08-30 A | 2013-08-30 A |  | 100% | 2013-09-03 | 2013-09-03 | PROCUREMENT>$50K 69 NO ESCALATION | 19,983.19 |  |  |  |  | 19983.19 |  |  |  |  |  |  |  |  |  |  | 0 | 19983.19 | 1998319 | 100 |  |  |  |  | ADJ |

| ID | WBS | Activity | Type | Duration | Start | Finish | Predecessors | Complete | Planned start | Planned finish | Resources | Cost | Actual cost | Calculated Remaining Total Cost | MONTHLY EV COST | RESP - Responsibility | STRT%COMP for CM EVM | FNSH%COMP for CM EVM | EVMS Reporting Codes | CAM RESPONSIBLE | CR 11-028 | Remaining Material Cost Based on % Compl | Claimed Material Cost Based on % Complet | Initial Claimed Material Calc | Claimed Material Divider | Installation | MARCH!!! | OPC Allison | ReBaseline Actuals Adjustment | LOE Divider | LOE Multiplier | CR 08-058 | LOE % Pre Calc | LOE % | CR 12-035 | CR 08-016 | CR 09-012 | CR 10-003 | CR 11-001 | CR 09-047 | CR 10-065 | Milestone Level |
| --- | --- | --- | --- | --- | --- | --- | --- | --- | --- | --- | --- | --- | --- | --- | --- | --- | --- | --- | --- | --- | --- | --- | --- | --- | --- | --- | --- | --- | --- | --- | --- | --- | --- | --- | --- | --- | --- | --- | --- | --- | --- | --- |
|  | 3 | **1.3.5.3 RESONANCE CONTROL** |  |  | 2012-03-02 | 2013-08-30 |  |  |  |  |  |  |  |  |  |  |  |  |  |  |  |  |  |  |  |  |  |  |  |  |  |  |  |  |  |  |  |  |  |  |  |  |
| 1353005 |  | Procure Resonance Control LABOR (RESONANCE Control) |  | 209d | 2012-03-02 A | 2012-12-17 A | 12153025M, 9-120M FS+60d | 100% | 2012-03-02 | 2013-01-03 | ELEC ENG [48 h]; MECH ENG [32 h]; ELEC TECH [20 h]; MECH DES [8 h]; MECH TECH [40 h] | 8,757.13 | 8,750.32 | 0 | 8676.28 | SPATA M | 1 | 1 | H | MIKE S | 11-028 |  |  |  |  |  |  |  |  |  |  |  |  |  |  |  |  |  |  |  |  |  |
| 1353005a |  | Procure Resonance Control MATERIAL (RESONANCE Control) |  | 178d | 2012-04-16 A | 2012-12-17 A | 1353005 FS-61d | 100% | 2012-04-16 | 2013-01-03 | PROCUREMENT<$50K 60 | 36,094.69 |  | 0 | 36094.69 | SPATA M | 1 | 1 | D | MIKE S | 11-028 | 0 | 36094.69 | 3609469 | 100 |  |  |  |  |  |  |  |  |  |  |  |  |  |  |  |  |  |
| 1353070 |  | Install Control Valves (RESONANCE Control) |  | 11d | 2012-11-05 A | 2012-11-19 A | 1353005a | 100% |  |  | MECH TECH [20 h]; ELEC TECH [20 h] | 1,828 | 1,828 | 0 | 1771.4 | SPATA M | 1 | 1 | H | MIKE S | 11-028 |  |  |  |  | Install |  |  |  |  |  |  |  |  |  |  |  |  |  |  |  |  |
| 1353020 |  | Assemble Heater Units (RESONANCE Control) |  | 60d | 2012-11-12 A | 2012-12-17 A | 1353005a FS-60d | 100% | 2012-11-12 | 2013-02-14 | ELEC TECH [20 h]; MECH TECH [140 h]; MECH DES [12 h] | 7,927.72 | 7,927.72 | 0 | 7682.24 | SPATA M | 1 | 1 | H | MIKE S | 11-028 |  |  |  |  |  |  |  |  |  |  |  |  |  |  |  |  |  |  |  |  |  |
| 1353085 |  | Move 5th pass Controls/Rack (RESONANCE Control) |  | 24d | 2012-11-12 A | 2013-01-21 A | 4A-01M, 9-120M FS+184d | 100% | 2012-11-12 | 2012-12-17 | ELEC TECH [40 h]; MECH TECH [60 h] | 4,573.2 | 4,573.2 | 0 | 4431.6 | SPATA M | 1 | 1 | H | MIKE S | 11-028 |  |  |  |  |  | XX |  |  |  |  |  |  |  |  |  |  |  |  |  |  |  |
| 1353040 |  | Modify Control Chassis (RESONANCE Control) |  | 29d | 2013-01-14 A | 2013-08-17 A | 1353005a | 100% | 2013-02-01 | 2013-03-14 | COMP SCIENT [160 h] | 10,833.6 | 10,833.6 | 5249.6 | 10499.2 | SPATA M | 1 | 1 | H | MIKE S | 11-028 |  |  |  |  | Install | XX |  |  |  |  |  |  |  |  |  |  |  |  |  |  |  |
| 1353095 |  | Sys Testing (RESONANCE Control) |  | 10d | 2013-08-05 A | 2013-08-19 A | 1353070, 1353085, 1353020, 1353040, 1351080 | 100% | 2013-10-24 | 2013-11-06 | ELEC ENG [112 h]; MECH TECH [60 h]; ELEC TECH [140 h]; MECH ENG [60 h]; MECH DES [20 h] | 23,338.56 | 22,617.72 | 22617.72 | 22617.72 | SPATA M | 1 | 1 | H | MIKE S | 11-028 |  |  |  |  |  |  | OPC A |  |  |  |  |  |  |  |  |  |  |  |  |  |  |
| 1353100 |  | Re-Baseline Actuals Adjustment |  | 1d | 2013-08-30 A | 2013-08-30 A |  | 100% | 2013-09-03 | 2013-09-03 | PROCUREMENT>$50K 69 NO ESCALATION | -38,313.59 |  |  |  |  |  |  |  |  |  |  |  |  | 100 |  |  |  | ADJ |  |  |  |  |  |  |  |  |  |  |  |  |  |
|  | 4 | **1.3.5.4 LAMBERTSON** |  |  | 2009-01-02 | 2013-08-30 |  |  |  |  |  |  |  |  |  |  |  |  |  |  |  |  |  |  |  |  |  |  |  |  |  |  |  |  |  |  |  |  |  |  |  |  |
| 1354909LOE |  | FY09 Engrng Oversight (LAMBERTSON) |  | 189d | 2009-01-02 A | 2009-09-30 A | 1354909LOEX | 100% |  |  | MECH ENG [60.97 h]; TRAVEL | 6,324.98 | 3,890.5 | 0 | 6324.974818 | SPATA M | 1 | 1 | E | MIKE S | 11-028 |  |  |  |  |  |  |  |  | 100 | 100 | 08-058 |  |  |  |  |  |  |  |  |  |  |
| 1354910LOE |  | FY10 Engrng Oversight (LAMBERTSON) |  | 248d | 2009-10-01 A | 2010-09-30 A | 1354909LOE | 100% |  |  | TRAVEL; MECH ENG [80 h] | 8,564.35 | 5,268 | 0 | 8564.352955 | SPATA M | 1 | 1 | E | MIKE S | 11-028 |  |  |  |  |  |  |  |  | 100 | 100 |  |  |  |  |  |  |  |  |  |  |  |
| 1354911LOE |  | FY11 Engrng Oversight (LAMBERTSON) |  | 120d | 2010-10-01 A | 2011-03-31 A | 1354910LOE | 100% |  |  | MECH ENG [38.71 h]; TRAVEL | 4,276.23 | 2,630.34 | 0 | 4276.2345 | SPATA M | 1 | 1 | E | MIKE S | 11-028 |  |  |  |  |  |  |  |  | 100 | 100 |  | 516129.0322 | -516029.0322 |  |  |  |  |  |  |  |  |
| 1354950 |  | Re-Baseline Actuals Adjustment |  | 1d | 2013-08-30 A | 2013-08-30 A |  | 100% | 2013-09-03 | 2013-09-03 | PROCUREMENT>$50K 69 NO ESCALATION | -16,873.42 |  |  |  |  |  |  |  |  |  |  |  |  | 100 |  |  |  | ADJ |  |  |  |  |  |  |  |  |  |  |  |  |  |
|  | 5 | **1.3.5.5 CHICANE** |  |  | 2009-08-17 | 2013-08-30 |  |  |  |  |  |  |  |  |  |  |  |  |  |  |  |  |  |  |  |  |  |  |  |  |  |  |  |  |  |  |  |  |  |  |  |  |
| 1355016 |  | Proc Septa Mag Iron & Coil Packs (CHICANE) |  | 2d | 2009-08-17 A | 2009-08-18 A | 12155050M, 12156045, 9-100M FS+60d | 100% |  |  | MECH DES [60 h]; MECH ENG [80 h] | 7,735.2 | 7,735.2 | 0 | 7982.4 | SPATA M | 1 | 1 | H | MIKE S |  |  |  |  |  |  |  |  |  |  |  |  |  |  | 12-035F |  |  |  |  |  |  |  |
| 1355910LOE |  | FY10 Mech Eng/Dsgner Oversight (CHICANE) |  | 248d | 2009-10-01 A | 2010-09-30 A | 1354909LOE | 100% |  |  | TRAVEL | 4,395.14 |  | 0 | 4395.140713 | SPATA M | 1 | 1 | E | MIKE S | 11-028 |  |  |  |  |  |  |  |  | 100 | 100 |  |  |  |  |  |  |  |  |  |  |  |
| 1355040 |  | Fab Dipole Magnets (CHICANE) Original Labor FY10 |  | 233d | 2010-04-21 A | 2011-03-31 A | 1355035 FS-80d | 100% | 2010-04-21 | 2011-03-30 | MECH DES [27.42 h]; MECH ENG [67.04 h] | 5,747.14 | 5,885.11 | 0 | 5655.0648 | SPATA M | 1 | 1 | E | MIKE S |  |  |  |  |  |  |  |  |  | 100 | 100 |  | 476404.4943 | -476304.4943 | 12-035F | 08-016 | 09-012 | 10-003 | 11-001 |  |  |  |
| 1355040a |  | Fab Dipole Magnets (CHICANE) Original Labor FY11 |  | 233d | 2010-04-21 A | 2011-03-31 A | 1355040 | 100% | 2010-04-21 | 2011-03-30 | MECH DES [29.13 h]; MECH ENG [71.19 h] | 6,103.48 | 6,217.24 | 0 | 6197.1489 | SPATA M | 1 | 1 | E | MIKE S | 11-028 |  |  |  |  |  |  |  |  | 100 | 100 |  | 476404.4943 | -476304.4943 | 12-035F | 08-016 | 09-012 | 10-003 | 11-001 |  |  |  |
| 1355018 |  | Insp Septa Matls (CHICANE) |  | 1d | 2010-04-26 A | 2010-04-26 A | 1355016, 13411087 | 100% |  |  | MECH ENG [4 h]; MECH TECH [20 h] | 1,098.2 | 1,098.2 | 0 | 1098.2 | SPATA M | 1 | 1 | H | MIKE S |  |  |  |  |  |  |  |  |  |  |  |  |  |  | 12-035F |  |  |  |  | 09-047 |  |  |
| 1355022 |  | Measure Septa Magnets (CHICANE) |  | 5d | 2010-04-26 A | 2010-04-30 A | 13411087D10 | 100% |  |  | MECH TECH [40 h]; MECH ENG [20 h] | 2,986.6 | 2,986.6 | 0 | 3180 | SPATA M | 1 | 1 | H | MIKE S |  |  |  |  |  |  |  |  |  |  |  |  |  |  | 12-035F |  |  |  |  | 09-047 | 10-065 |  |
| 1355030 |  | Proc Dipole Mag Iron & Coil Packs (CHICANE) |  | 5d | 2010-04-26 A | 2010-04-30 A | 9-100M FS+60d, 12156045, 12155050M | 100% |  |  | MECH DES [52 h]; MECH ENG [52 h] | 5,776.68 | 5,776.68 | 0 | 5776.68 | SPATA M | 1 | 1 | H | MIKE S |  |  |  |  |  |  |  |  |  |  |  |  |  |  | 12-035F |  |  |  |  |  |  |  |
| 1355035 |  | Insp Dipole Matls (CHICANE) |  | 5d | 2010-04-26 A | 2010-04-30 A | 1355030 | 100% |  |  | MECH ENG [4 h]; MECH TECH [20 h] | 1,098.2 | 1,098.2 | 0 | 1098.2 | SPATA M | 1 | 1 | H | MIKE S |  |  |  |  |  |  |  |  |  |  |  |  |  |  | 12-035F |  |  |  |  |  |  |  |
| 1355025M |  | Extraction Septas Ready for Installtn (CHICANE) | milestone | 0d | 2010-04-30 A | 2010-04-30 A | 1355018, 1355022 | 100% | 2012-01-03 | 2012-01-03 |  |  |  |  | 0 | SPATA M | 1 | 1 | M | MIKE S |  |  |  |  |  |  |  |  |  |  |  |  |  |  | 12-035F |  |  |  |  |  | 10-065 | 6 |
| 1355911LOE |  | FY11 Mech Eng/Dsgner Oversight (CHICANE) |  | 120d | 2010-10-01 A | 2011-03-31 A | 1355910LOE | 100% |  |  | TRAVEL | 2,194.53 |  | 0 | 2194.53 | SPATA M | 1 | 1 | E | MIKE S | 11-028 |  |  |  |  |  |  |  |  | 100 | 100 |  | 516129.0322 | -516029.0322 |  |  |  |  |  |  |  |  |
| 1355950 |  | Re-Baseline Actuals Adjustment |  | 1d | 2013-08-30 A | 2013-08-30 A |  | 100% | 2013-09-03 | 2013-09-03 | PROCUREMENT>$50K 69 NO ESCALATION | -37,577.57 |  |  |  |  |  |  |  |  |  |  |  |  | 100 |  |  |  | ADJ |  |  |  |  |  |  |  |  |  |  |  |  |  |

| ID | WBS | Activity | Type | Duration | Start | Finish | Predecessors | Complete | Remaining | Planned start | Planned finish | Total float | Free float | Calendar | Resources | Cost | Actual cost | LOE Divider | LOE Multiplier | Calculated Remaining Total Cost | MONTHLY EV COST | RESP - Responsibility | STRT%COMP for CM EVM | FNSH%COMP for CM EVM | EVMS Reporting Codes | CAM RESPONSIBLE | CR 11-028 | LOE % Pre Calc | LOE % | Remaining Material Cost Based on % Compl | Claimed Material Cost Based on % Complet | Initial Claimed Material Calc | Claimed Material Divider | CR 12-035 | MARCH!!! | ReBaseline Actuals Adjustment | CR 08-058 | Advance Purchase Plan > 500K | CR 08-040 | CR 08-051 | 12 GEV MAJOR PROCUREMENT CATAGORY | CR 10-031 | CR 11-014 | CR 11-026 | CR 12-005 | CR 10-070 | CR 12-018 | CR 12-026 | OPC Allison | CR 12-001 | New H Claim | CR 08-016 | CR 09-012 | Activities with Steps | Milestone Level | Original Activity ID Rebaseline | PRIOR MONTH EV COST | BOE Labor | CR 13-015 | Post Rebaseline | CR 14-001 | BOE Procurement | Obligated Prior to Rebaseline |
| --- | --- | --- | --- | --- | --- | --- | --- | --- | --- | --- | --- | --- | --- | --- | --- | --- | --- | --- | --- | --- | --- | --- | --- | --- | --- | --- | --- | --- | --- | --- | --- | --- | --- | --- | --- | --- | --- | --- | --- | --- | --- | --- | --- | --- | --- | --- | --- | --- | --- | --- | --- | --- | --- | --- | --- | --- | --- | --- | --- | --- | --- | --- | --- |
|  | 6 | **1.3.5.6 STANDS** |  |  | 2009-10-01 | 2013-08-30 |  |  |  |  |  |  |  |  |  |  |  |  |  |  |  |  |  |  |  |  |  |  |  |  |  |  |  |  |  |  |  |  |  |  |  |  |  |  |  |  |  |  |  |  |  |  |  |  |  |  |  |  |  |  |  |  |  |
| 1356910LOE |  | FY10 Mech Eng/Dsgner Oversight (Stands) |  | 248d | 2009-10-01 A | 2010-09-30 A | 1354909LOE | 100% |  |  |  |  |  |  | TRAVEL | 2,197.58 |  | 100 | 100 | 0 | 2197.575516 | SPATA M | 1 | 1 | E | MIKE S | 11-028 |  |  |  |  |  |  |  |  |  |  |  |  |  |  |  |  |  |  |  |  |  |  |  |  |  |  |  |  |  |  |  |  |  |  |  |  |
| 1356911LOE |  | FY11 Mech Eng/Dsgner Oversight (Stands) |  | 120d | 2010-10-01 A | 2011-03-31 A | 1356910LOE | 100% |  |  |  |  |  |  | TRAVEL | 1,097.26 |  | 100 | 100 | 0 | 1097.26 | SPATA M | 1 | 1 | E | MIKE S | 11-028 | 516129.0322 | -516029.0322 |  |  |  |  |  |  |  |  |  |  |  |  |  |  |  |  |  |  |  |  |  |  |  |  |  |  |  |  |  |  |  |  |  |  |
| 1356018 |  | Proc Stands Matls (Stands) |  | 202d | 2012-03-02 A | 2013-03-11 A | 9-120M FS+70d, 12156045, 12156040M, 9-110M FS+45d | 100% |  | 2012-03-02 | 2012-12-17 |  |  |  | PROCUREMENT<$50K 60; MECH DES [8 h]; MECH ENG [100 h] | 20,272.88 | 7,495.98 |  |  | 0 | 19980.79 | SPATA M | 1 | 1 | H | MIKE S | 11-028 |  |  | 0 | 12812.35 | 1281235 | 100 | 12-035F | XX |  |  |  |  |  |  |  |  |  |  |  |  |  |  |  |  |  |  |  |  |  |  |  |  |  |  |  |  |
| 1356020 |  | Insp Matls (Stands) |  | 11d | 2013-03-13 A | 2013-03-28 A | 1356018 | 100% |  | 2013-05-13 | 2013-05-28 |  |  |  | MECH TECH [22 h]; MECH ENG [6.6 h] | 1,486.5 | 1,486.5 |  |  | 0 | 1396.01 | SPATA M | 1 | 1 | H | MIKE S | 11-028 |  |  |  |  |  |  | 12-035F | XX |  |  |  |  |  |  |  |  |  |  |  |  |  |  |  |  |  |  |  |  |  |  |  |  |  |  |  |  |
| 1356950 |  | Re-Baseline Actuals Adjustment |  | 1d | 2013-08-30 A | 2013-08-30 A |  | 100% |  | 2013-09-03 | 2013-09-03 |  |  |  | PROCUREMENT>$50K 69 NO ESCALATION | 170.96 |  |  |  |  | 170.96 |  |  |  |  |  |  |  |  | 0 | 170.96 | 17096 | 100 |  |  | ADJ |  |  |  |  |  |  |  |  |  |  |  |  |  |  |  |  |  |  |  |  |  |  |  |  |  |  |  |
|  | 6 | **1.3.6 INSTRUMENTATION/CONTROLS/SAFETY SYS** |  |  | 2009-01-02 | 2014-10-30 |  |  |  |  |  |  |  |  |  |  |  |  |  |  |  |  |  |  |  |  |  |  |  |  |  |  |  |  |  |  |  |  |  |  |  |  |  |  |  |  |  |  |  |  |  |  |  |  |  |  |  |  |  |  |  |  |  |
|  | 1 | **1.3.6.1 BEAM DIAGNOSTICS** |  |  | 2009-01-02 | 2014-10-30 |  |  |  |  |  |  |  |  |  |  |  |  |  |  |  |  |  |  |  |  |  |  |  |  |  |  |  |  |  |  |  |  |  |  |  |  |  |  |  |  |  |  |  |  |  |  |  |  |  |  |  |  |  |  |  |  |  |
|  | 1 | **1.3.6.1.1 BPM'S** |  |  | 2009-01-02 | 2014-10-30 |  |  |  |  |  |  |  |  |  |  |  |  |  |  |  |  |  |  |  |  |  |  |  |  |  |  |  |  |  |  |  |  |  |  |  |  |  |  |  |  |  |  |  |  |  |  |  |  |  |  |  |  |  |  |  |  |  |
| 13611909LOE |  | FY09 Mngmnt Effort for BPMs |  | 189d | 2009-01-02 A | 2009-09-30 A | 13611909LOEX | 100% |  |  |  |  |  |  | SR STAFF [6.1 h] | 627.32 | 627.32 | 100 | 100 | 0 | 627.323585 | GARZA O | 1 | 1 | E | MIKE S |  |  |  |  |  |  |  |  |  |  | 08-058 |  |  |  |  |  |  |  |  |  |  |  |  |  |  |  |  |  |  |  |  |  |  |  |  |  |  |
| 13611910LOE |  | FY10 Mngmnt Effort for BPMs |  | 248d | 2009-10-01 A | 2010-09-30 A | 13611909LOE | 100% |  |  |  |  |  |  | SR STAFF [8 h] | 848.96 | 848.96 | 100 | 100 | 0 | 848.96 | GARZA O | 1 | 1 | E | MIKE S |  |  |  |  |  |  |  |  |  |  |  |  |  |  |  |  |  |  |  |  |  |  |  |  |  |  |  |  |  |  |  |  |  |  |  |  |  |
| 13611911LOE |  | FY11 Mngmnt Effort for BPMs |  | 248d | 2010-10-01 A | 2011-09-30 A | 13611910LOE | 100% |  |  |  |  |  |  | SR STAFF [88 h] | 9,636.88 | 9,636.88 | 100 | 100 | 0 | 9636.88 | GARZA O | 1 | 1 | E | MIKE S |  | 8.46774193 | 91.53225806 |  |  |  |  |  |  |  |  |  |  |  |  |  |  |  |  |  |  |  |  |  |  |  |  |  |  |  |  |  |  |  |  |  |  |
| 13611014 |  | Labor - SEE BPMs CANS Accelerator |  | 465d | 2010-12-01 A | 2012-10-15 A | 9-110M FS+25d, 121611055M | 100% |  |  |  |  |  |  | ELEC ENG [12 h]; ELEC TECH [16 h] | 1,532.64 | 1,532.64 |  |  | 0 | 1504.88 | GARZA O | 1 | 1 | H | MIKE S |  |  |  |  |  |  |  |  |  |  |  | APP | 08-040 | 08-051 | 3611A | 10-031 | 11-014 | 11-026 | 12-005 |  |  |  |  |  |  |  |  |  |  |  |  |  |  |  |  |  |  |
| 13611014A |  | Prcrmnt - SEE BPMs CANS Accelerator |  | 192d | 2011-03-01 A | 2011-11-30 A | 13611014 FS-50d, 9-110M FS+25d | 100% |  |  |  |  |  |  | PROCUREMENT<$50K 60 | 155,018 |  |  |  | 0 | 155018 | GARZA O | 1 | 1 | U | MIKE S |  |  |  | 0 | 155018 | 15501800 | 100 |  |  |  |  | APP |  |  | 3611A | 10-031 | 11-014 | 11-026 | 12-005 |  |  |  |  |  |  |  |  |  |  |  |  |  |  |  |  |  |  |
| 13611014Aa |  | Testing - SEE BPM Compnts CANS Accelerator |  | 126d | 2011-05-16 A | 2011-11-10 A | 13611014A FS-65d | 100% |  |  |  |  |  |  | COMP SCIENT [24 h]; ELEC ENG [24 h]; ELEC TECH [68 h] | 6,120.18 | 6,120.18 |  |  | 0 | 6075.64 | GARZA O | 1 | 1 | H | MIKE S |  |  |  |  |  |  |  |  |  |  |  | APP |  |  | 3611A |  | 11-014 | 11-026 | 12-005 |  |  |  |  |  |  |  |  |  |  |  |  |  |  |  |  |  |  |
| 13611912LOE |  | FY12 Mngmnt Effort for BPMs |  | 247d | 2011-10-03 A | 2012-09-28 A | 13611911LOE | 100% |  |  |  |  |  |  | SR STAFF [88 h] | 9,944 | 9,944 | 100 | 100 | 0 | 9944 | GARZA O | 1 | 1 | E | MIKE S |  | 7.69230769 | 92.3076923 |  |  |  |  |  |  |  |  |  |  |  |  |  |  |  |  |  |  |  |  |  |  |  |  |  |  |  |  |  |  |  |  |  |  |
| 13611014Ab |  | Labor - SEE BPMs CANS Hall D |  | 156d | 2012-01-03 A | 2012-08-13 A | 9-120M, 9-110M FS+141d | 100% |  |  |  |  |  |  | ELEC ENG [12 h]; ELEC TECH [16 h] | 1,552.8 | 1,552.8 |  |  | 0 | 1504.88 | GARZA O | 1 | 1 | H | MIKE S |  |  |  |  |  |  |  |  |  |  |  | APP |  |  | 3611A |  | 11-014 | 11-026 | 12-005 |  |  |  |  |  |  |  |  |  |  |  |  |  |  |  |  |  |  |
| 13611026 |  | Labor - West ARC Completion BPMs |  | 239d | 2012-01-03 A | 2013-08-12 A | 9-120M FS+60d | 100% |  | 2012-01-03 | 2012-12-11 |  |  |  | ELEC TECH [1120 h] | 49,755.98 | 50,264.18 |  |  | 4942.56 | 49425.6 | GARZA O | 1 | 1 | U | MIKE S |  |  |  |  |  |  |  | 12-035F | XX |  |  |  |  |  |  | 10-031 |  | 11-026 | 12-005 | 10-070 | 12-018F |  |  |  |  |  |  |  |  |  |  |  |  |  |  |  |  |
| 13611014Af |  | RF Receiver - First Article Unit SEE BPM |  | 200d | 2012-02-01 A | 2012-11-12 A | 9-120M FS+78d | 100% |  |  |  |  |  |  | ELEC ENG [392 h] | 27,796.23 | 27,796.23 |  |  | 0 | 27659.52 | GARZA O | 1 | 1 | H | MIKE S |  |  |  |  |  |  |  |  |  |  |  |  |  |  |  |  |  |  | 12-005 |  |  | 12-026F |  |  |  |  |  |  |  |  |  |  |  |  |  |  |  |
| 13611014Ag |  | Digital IF - First Article Unit SEE BPM |  | 231d | 2012-02-01 A | 2012-12-17 A | 9-120M FS+78d | 100% |  | 2012-02-01 | 2013-01-04 |  |  |  | ELEC ENG [392 h] | 27,896.25 | 27,873.1 |  |  | 0 | 27659.52 | GARZA O | 1 | 1 | H | MIKE S |  |  |  |  |  |  |  |  |  |  |  |  |  |  |  |  |  |  | 12-005 |  |  | 12-026F |  |  |  |  |  |  |  |  |  |  |  |  |  |  |  |
| 13611026a |  | Procurement - West ARC Completion BPMs |  | 58d | 2012-02-01 A | 2012-04-23 A | 13611026 FS-200d | 100% |  |  |  |  |  |  | PROCUREMENT<$50K 60 | 8,000 |  |  |  | 0 | 8000 | GARZA O | 1 | 1 | D | MIKE S |  |  |  | 0 | 8000 | 800000 | 100 | 12-035F |  |  |  |  |  |  |  | 10-031 |  | 11-026 | 12-005 | 10-070 | 12-018F |  |  |  |  |  |  |  |  |  |  |  |  |  |  |  |  |
| 13611065 |  | System Documentation - BPMs First Article |  | 219d | 2012-02-01 A | 2012-12-17 A | 13611014Af FS-80d | 100% |  | 2012-02-01 | 2012-12-11 |  |  |  | ELEC DES [496 h] | 25,235.28 | 25,246.33 |  |  | 0 | 25052.96 | GARZA O | 1 | 1 | H | MIKE S |  |  |  |  |  |  |  |  |  |  |  |  |  |  |  | 10-031 |  |  | 12-005 | 10-070 |  | 12-026 |  |  |  |  |  |  |  |  |  |  |  |  |  |  |  |
| 13611014Ac |  | Prcrmnt - SEE BPMs CANS Hall D |  | 89d | 2012-04-09 A | 2012-08-13 A | 13611014Ab FS-20d | 100% |  |  |  |  |  |  | PROCUREMENT<$50K 60 | 72,000 |  |  |  | 0 | 72000 | GARZA O | 1 | 1 | D | MIKE S |  |  |  | 0 | 72000 | 7200000 | 100 |  |  |  |  | APP |  |  | 3611A |  | 11-014 | 11-026 | 12-005 |  |  |  | OPC A |  |  |  |  |  |  |  |  |  |  |  |  |  |  |
| 13611014Ah |  | RF Receiver Enclosure - First Article Unit SEE BPM |  | 94d | 2012-06-05 A | 2012-10-15 A | 13611014Ag FS-65d, 13611014Af FS-65d | 100% |  |  |  |  |  |  | ELEC TECH [544 h]; ELEC ENG [544 h] | 62,624.35 | 62,624.35 |  |  | 0 | 62391.36 | GARZA O | 1 | 1 | D | MIKE S |  |  |  |  |  |  |  |  |  |  |  |  |  |  |  |  |  |  | 12-005 |  |  | 12-026F |  |  |  |  |  |  |  |  |  |  |  |  |  |  |  |
| 13611026b |  | Hook-up & Check-out Arc 10 BPMs |  | 135d | 2012-06-05 A | 2013-08-30 A | 13611026 FS-50d, 13611026a | 100% |  | 2012-06-05 | 2012-12-13 |  |  |  | COMP SCIENT [80 h]; ELEC TECH [80 h] | 8,887.85 | 8,985.28 |  |  | 4390 | 8780 | GARZA O | 1 | 1 | H | MIKE S |  |  |  |  |  |  |  | 12-035F | XX |  |  |  |  |  |  | 10-031 |  | 11-026 | 12-005 | 10-070 | 12-018F |  |  |  |  |  |  |  |  |  |  |  |  |  |  |  |  |
| 13611014Ad |  | Testing - SEE BPM Compnts CANS Hall D FY11 |  | 50d | 2012-08-06 A | 2012-10-15 A | 13611014Ac | 100% |  |  |  |  |  |  | ELEC TECH [67.11 h]; ELEC ENG [15.79 h] | 4,104.34 | 4,104.34 |  |  | 0 | 3950.0149 | GARZA O | 1 | 1 | H | MIKE S |  |  |  |  |  |  |  |  |  |  |  | APP |  |  | 3611A |  | 11-014 | 11-026 | 12-005 |  |  |  | OPC A | 12-001 | Aug 12 |  |  |  |  |  |  |  |  |  |  |  |  |
| 13611014B |  | Procurement Labor - SEE BPMs ELECTRONICS |  | 136d | 2012-10-01 A | 2013-08-30 A | 9-130M | 100% |  | 2012-10-01 | 2013-04-22 |  |  |  | ELEC TECH [240 h]; ELEC ENG [240 h] | 28,404 | 28,404 |  |  | 14202 | 28404 | GARZA O | 1 | 1 | H | MIKE S |  |  |  |  |  |  |  |  |  |  |  | APP |  |  | 3611A | 10-031 |  | 11-026 | 12-005 | 10-070 |  | 12-026 | OPC A |  |  |  |  |  |  |  |  |  |  |  |  |  |  |
| 13611025b |  | System Installation Software Support First Article - Electronics SEE BPMs |  | 63d | 2012-10-01 A | 2013-04-15 A | 13611014Ah FS-30d | 100% |  | 2012-10-01 | 2013-01-07 |  |  |  | COMP SCIENT [320 h] | 21,667.2 | 21,667.2 |  |  | 0 | 20998.4 | GARZA O | 1 | 1 | H | MIKE S |  |  |  |  |  |  |  |  | XX |  |  |  |  |  |  |  |  |  | 12-005 |  |  |  |  |  |  |  |  |  |  |  |  |  |  |  |  |  |  |
| 13611913LOE |  | FY13 Mngmnt Effort for BPMs |  | 248d | 2012-10-01 A | 2013-08-30 A | 13611912LOE | 100% |  | 2012-10-01 | 2013-09-30 |  |  |  | SR STAFF [80.9 h] | 9,432.94 | 9,445.08 | 100 | 100 | 1738.17952 | 9432.94 | GARZA O | 1 | 1 | E | MIKE S |  | 8.06451612 | 91.93548387 |  |  |  |  |  |  |  |  |  |  |  |  |  |  |  |  |  |  |  | OPC A |  |  |  |  |  |  |  |  |  |  |  |  |  |  |
| 13611014Ada |  | Testing - SEE BPM Compnts CANS Hall D FY12 |  | 6d | 2012-10-15 A | 2012-10-22 A | 13611014Ad | 100% |  |  |  |  |  |  | ELEC ENG [0.21 h]; ELEC TECH [0.89 h] | 55.82 | 55.82 |  |  | 0 | 54.0933 | GARZA O | 1 | 1 | H | MIKE S |  |  |  |  |  |  |  |  |  |  |  | APP |  |  | 3611A |  | 11-014 | 11-026 | 12-005 |  |  |  | OPC A | 12-001 |  |  |  |  |  |  |  |  |  |  |  |  |  |
| 13611065a |  | System Documentation - BPMs |  | 215d | 2012-10-15 A | 2013-08-30 A | 9-130M | 100% |  | 2012-10-15 | 2013-08-27 |  |  |  | ELEC DES [744 h] | 38,777.28 | 38,777.28 |  |  | 19388.64 | 38777.28 | GARZA O | 1 | 1 | H | MIKE S |  |  |  |  |  |  |  |  |  |  |  |  |  |  |  | 10-031 |  |  | 12-005 | 10-070 |  | 12-026 | OPC A |  |  |  |  |  |  |  |  |  |  |  |  |  |  |
| 13611070 |  | First Article Unit - Power Supply SEE BPMs |  | 124d | 2012-11-12 A | 2013-02-11 A | 9-130M, 13611014Ah | 100% |  | 2012-11-12 | 2013-05-16 |  |  |  | ELEC ENG [240 h]; ELEC TECH [240 h] | 28,404 | 28,404 |  |  | 0 | 28404 | GARZA O | 1 | 1 | H | MIKE S |  |  |  |  |  |  |  |  |  |  |  |  |  |  |  |  |  |  | 12-005 |  |  | 12-026 | OPC A |  |  |  |  |  |  |  |  |  |  |  |  |  |  |
| 13611075 |  | Procurement Labor - Power Supply SEE BPMs |  | 130d | 2012-11-12 A | 2013-08-30 A | 13611070 FS-125d | 100% |  | 2012-11-12 | 2013-05-24 |  |  |  | ELEC TECH [200 h] | 9,108 | 9,108 |  |  | 4554 | 9108 | GARZA O | 1 | 1 | H | MIKE S |  |  |  |  |  |  |  |  |  |  |  |  |  |  |  |  |  |  | 12-005 |  |  | 12-026 | OPC A |  |  |  |  |  |  |  |  |  |  |  |  |  |  |
| 13611080 |  | Procurement - Power Supply SEE BPMs |  | 130d | 2012-11-12 A | 2013-08-30 A | 13611075 FS-125d | 100% |  | 2012-11-12 | 2013-05-24 |  |  |  | PROCUREMENT<$50K 60 | 30,441.05 |  |  |  | 18264.63 | 30441.05 | GARZA O | 1 | 1 | D | MIKE S |  |  |  | 0 | 30441.05 | 3044105 | 100 |  |  |  |  |  |  |  |  |  |  |  | 12-005 |  |  | 12-026 | OPC A |  |  |  |  |  |  |  |  |  |  |  |  |  |  |
| 13611014C |  | Prcrmnt - SEE BPMs ELECTRONICS |  | 117d | 2012-12-03 A | 2013-08-30 A | 9-130M | 100% |  | 2013-02-01 | 2013-07-18 |  |  |  | PROCUREMENT<$50K 60 | 175,423 |  |  |  | 52626.9 | 175423 | GARZA O | 1 | 1 | D | MIKE S |  |  |  | 0 | 175423 | 17542300 | 100 |  |  |  |  | APP |  |  | 3611A | 10-031 |  | 11-026 | 12-005 | 10-070 |  | 12-026 | OPC A |  |  |  |  |  |  |  |  |  |  |  |  |  |  |
| 13611025 |  | System Installation - Electronics SEE BPMs |  | 49d | 2013-01-21 A | 2013-08-30 A | 13611015B FS-160d, 13611014Ada, 1362025 FS-115d, 13611014Aa | 100% |  | 2013-08-21 | 2013-10-29 |  |  |  | ELEC TECH [392 h] | 18,095.28 | 17,851.68 |  |  | 6783.6384 | 10565.28 | GARZA O | 1 | 1 | U | MIKE S |  |  |  |  |  |  |  |  |  |  |  | APP | 08-040 | 08-051 |  | 10-031 |  | 11-026 | 12-005 | 10-070 |  | 12-026 | OPC A |  |  | 08-016 | 09-012 |  |  |  |  |  |  |  |  |  |  |
| 13611036 |  | First Article Cavities - nA BPM Sys |  | 58d | 2013-02-01 A | 2013-08-30 A | 9-130M FS+80d | 100% |  | 2013-03-01 | 2013-05-21 |  |  |  | ELEC ENG [464 h]; MECH TECH [240 h] | 44,790.24 | 44,790.24 |  |  | 22395.12 | 44790.24 | GARZA O | 1 | 1 | H | MIKE S |  |  |  |  |  |  |  |  |  |  |  |  |  |  |  |  |  |  | 12-005 |  |  | 12-026 | OPC A |  |  |  |  |  |  |  |  |  |  |  |  |  |  |
| 13611015A |  | Labor - Fab & Assy - SEE BPMs ELECTRONICS |  | 83d | 2013-03-11 A | 2013-08-30 A | 13611014B FS-40d, 13611014C FS-75d | 100% |  | 2013-05-22 | 2013-09-18 |  |  |  | ELEC TECH [664 h]; ELEC ENG [664 h] | 78,584.4 | 78,584.4 |  |  | 47150.64 | 78584.4 | GARZA O | 1 | 1 | U | MIKE S |  |  |  |  |  |  |  |  |  |  |  | APP |  |  |  | 10-031 |  | 11-026 | 12-005 | 10-070 |  | 12-026 | OPC A |  |  |  |  |  |  |  |  |  |  |  |  |  |  |
| 13611025c |  | System Installation Software Support - Electronics SEE BPMs |  | 70d | 2013-04-08 A | 2013-08-30 A | 13611014Ag, 13611015B FS-120d, 13611025b | 100% |  | 2013-09-20 | 2014-01-07 |  |  |  | COMP SCIENT [72 h] | 5,015.09 | 4,875.12 |  |  | 18958.8 | 4875.12 | GARZA O | 1 | 1 | H | MIKE S |  |  |  |  |  |  |  |  |  |  |  |  |  |  |  |  |  |  | 12-005 |  |  | 12-026 | OPC A |  |  |  |  |  |  |  |  |  |  |  |  |  |  |
| 13611085 |  | Assembly Labor - Power Supply SEE BPMs |  | 100d | 2013-04-08 A | 2013-08-30 A | 13611080 FS-20d, 13611075 FS-20d | 100% |  | 2013-06-27 | 2013-11-15 |  |  |  | ELEC TECH [544 h] | 25,041.95 | 24,773.76 |  |  | 18216 | 24773.76 | GARZA O | 1 | 1 | H | MIKE S |  |  |  |  |  |  |  |  |  |  |  |  |  |  |  |  |  |  | 12-005 |  |  | 12-026 | OPC A |  |  |  |  |  |  |  |  |  |  |  |  |  |  |
| 13611015B |  | Procrmnt - Fab/Assy & Testing - SEE BPMs ELECTRONICS |  | 68d | 2013-06-03 A | 2013-08-30 A | 13611015A FS-83d, 13611014C FS-68d, 13611014B FS-15d | 100% |  | 2013-07-24 | 2013-10-28 |  |  |  | PROCUREMENT<$50K 60 | 77,392.5 |  |  |  | 54174.75 | 77392.5 | GARZA O | 1 | 1 | D | MIKE S |  |  |  | 0 | 77392.5 | 7739250 | 100 |  |  |  |  | APP |  |  |  | 10-031 |  | 11-026 | 12-005 | 10-070 |  | 12-026 | OPC A |  |  |  |  |  |  |  |  |  |  |  |  |  |  |
| 13611037 |  | Procurement Labor Cavities - nA BPM Sys |  | 20d | 2013-08-30 A | 2013-08-30 A | 13611036 | 100% |  | 2013-09-27 | 2013-10-24 |  |  |  | ELEC TECH [80 h]; MECH TECH [80 h] | 7,521.52 | 7,312 |  |  | 7312 | 7312 | GARZA O | 1 | 1 | H | MIKE S |  |  |  |  |  |  |  |  |  |  |  |  |  |  |  |  |  |  | 12-005 |  |  | 12-026 | OPC A |  |  |  |  |  |  |  |  |  |  |  |  |  |  |
| 13611037a |  | Procurement Cavities - nA BPM Sys |  | 20d | 2013-08-30 A | 2013-08-30 A | 13611037 FS-20d, 13611036 FS-1d | 100% |  | 2013-09-27 | 2013-10-24 |  |  |  | PROCUREMENT<$50K 60 | 136,210.8 |  |  |  | 136210.8 | 136210.8 | GARZA O | 1 | 1 | P | MIKE S |  |  |  | 0 | 136210.8 | 13621080 | 100 |  |  |  |  |  |  |  |  |  |  |  | 12-005 |  |  | 12-026 | OPC A |  |  |  |  |  |  |  |  |  |  |  |  |  |  |
| 13611038 |  | First Article Unit RF Receiver - nA BPM Sys |  | 68d | 2013-08-30 A | 2013-08-30 A | 9-130M FS+80d | 100% |  | 2013-09-03 | 2013-12-09 |  |  |  | ELEC ENG [400 h] | 29,779.06 | 29,124 |  |  | 29124 | 29124 | GARZA O | 1 | 1 | H | MIKE S |  |  |  |  |  |  |  |  |  |  |  |  |  |  |  |  |  |  | 12-005 |  |  | 12-026 | OPC A |  |  |  |  |  |  |  |  |  |  |  |  |  |  |
| 13611038a |  | First Article Unit Digital IF - nA BPM Sys |  | 48d | 2013-08-30 A | 2013-08-30 A | 9-130M FS+80d | 100% |  | 2013-09-03 | 2013-11-07 |  |  |  | ELEC ENG [320 h] | 23,732.27 | 23,299.2 |  |  | 23299.2 | 23299.2 | GARZA O | 1 | 1 | H | MIKE S |  |  |  |  |  |  |  |  |  |  |  |  |  |  |  |  |  |  | 12-005 |  |  | 12-026 | OPC A |  |  |  |  |  |  |  |  |  |  |  |  |  |  |
| 13611038b |  | First Article Enclosure nA Receiver - nA BPM Sys |  | 19d | 2013-08-30 A | 2013-08-30 A | 13611038a, 13611038 | 100% |  | 2013-12-10 | 2014-01-13 |  |  |  | ELEC TECH [152 h]; ELEC ENG [80 h] | 13,152.88 | 12,746.88 |  |  | 12746.88 | 12746.88 | GARZA O | 1 | 1 | H | MIKE S |  |  |  |  |  |  |  |  |  |  |  |  |  |  |  |  |  |  | 12-005 |  |  | 12-026 | OPC A |  |  |  |  |  |  |  |  |  |  |  |  |  |  |
| 13611039 |  | Procurement Labor Electronics - nA BPM Sys |  | 38d | 2013-08-30 A | 2013-08-30 A | 9-130M FS+80d | 100% |  | 2013-09-03 | 2013-10-24 |  |  |  | ELEC TECH [304 h]; ELEC ENG [120 h] | 22,922.03 | 22,581.36 |  |  | 22581.36 | 22581.36 | GARZA O | 1 | 1 | H | MIKE S |  |  |  |  |  |  |  |  |  |  |  |  |  |  |  |  |  |  | 12-005 |  |  | 12-026 | OPC A |  |  |  |  |  |  |  |  |  |  |  |  |  |  |
| 13611040 |  | Procurements Electronics - nA BPM Sys |  | 38d | 2013-08-30 A | 2013-08-30 A | 13611039 FS-38d, 121611055M | 100% |  | 2013-09-03 | 2013-10-24 |  |  |  | PROCUREMENT<$50K 60 | 40,760.05 |  |  |  | 40760.05 | 40760.05 | GARZA O | 1 | 1 | D | MIKE S |  |  |  | 0 | 40760.05 | 4076005 | 100 |  |  |  |  | APP |  |  |  |  |  |  | 12-005 | 10-070 |  | 12-026 | OPC A |  |  |  |  |  |  |  |  |  |  |  |  |  |  |
| 13611045 |  | Assembly Electronics Labor - nA BPM Sys |  | 83d | 2013-08-30 A | 2013-08-30 A | 13611040 FS-1d | 100% |  | 2013-10-24 | 2014-03-03 |  |  |  | ELEC ENG [80 h]; ELEC TECH [400 h] | 24,806.4 | 24,040.8 |  |  | 24040.8 | 24040.8 | GARZA O | 1 | 1 | S | MIKE S |  |  |  |  |  |  |  |  |  |  |  | APP |  |  |  |  |  |  | 12-005 | 10-070 |  | 12-026 | OPC A |  |  |  |  | ST |  |  |  |  |  |  |  |  |  |
| 13611050 |  | Assembly & Testing Procurement - nA BPM Sys |  | 83d | 2013-08-30 A | 2013-08-30 A | 13611045 FS-83d, 13611040 FS-1d | 100% |  | 2013-10-24 | 2014-03-03 |  |  |  | PROCUREMENT<$50K 60 | 8,255.2 |  |  |  | 8255.2 | 8255.2 | GARZA O | 1 | 1 | S | MIKE S |  |  |  | 0 | 8255.2 | 825520 | 100 |  |  |  |  |  |  |  |  |  |  |  | 12-005 | 10-070 |  | 12-026 | OPC A |  |  |  |  | ST |  |  |  |  |  |  |  |  |  |
| 13611055 |  | System Installation Electronics - nA BPM Sytem (BPM) |  | 25d | 2013-08-30 A | 2013-08-30 A | 13611037a, 13611038b, 1362025, 13611065, 13611050 | 100% |  | 2014-03-04 | 2014-04-07 |  |  |  | ELEC TECH [200 h] | 9,398 | 9,108 |  |  | 9108 | 9108 | GARZA O | 1 | 1 | H | MIKE S |  |  |  |  |  |  |  |  |  |  |  | APP |  |  |  | 10-031 |  |  | 12-005 | 10-070 |  | 12-026 | OPC A |  |  | 08-016 | 09-012 |  |  |  |  |  |  |  |  |  |  |
| 13611055a |  | System Installation Electronics Contract Labor - nA BPM Sytem (BPM) |  | 25d | 2013-08-30 A | 2013-08-30 A | 13611037a, 13611038b, 13611055 FS-25d, 13611065 | 100% |  | 2014-03-04 | 2014-04-07 |  |  |  | PROCUREMENT<$50K 60 | 16,510.4 |  |  |  | 16510.4 | 16510.4 | GARZA O | 1 | 1 | P | MIKE S |  |  |  | 0 | 16510.4 | 1651040 | 100 |  |  |  |  | APP |  |  |  |  |  |  | 12-005 |  |  | 12-026 | OPC A |  |  |  |  |  |  |  |  |  |  |  |  |  |  |
| 13611060 |  | Software support - nA BPMs |  | 80d | 2013-08-30 A | 2013-08-30 A | 13611055 FS-80d, 13611050 FS-60d | 100% |  | 2013-12-05 | 2014-04-07 |  |  |  | COMP SCIENT [640 h] | 44,716.8 | 43,334.4 |  |  | 43334.4 | 43334.4 | GARZA O | 1 | 1 | S | MIKE S |  |  |  |  |  |  |  |  |  |  |  |  |  |  |  | 10-031 |  |  | 12-005 | 10-070 |  | 12-026 | OPC A |  |  |  |  | ST |  |  |  |  |  |  |  |  |  |
| 13611950 |  | Re-Baseline Actuals Adjustment |  | 1d | 2013-08-30 A | 2013-08-30 A |  | 100% |  | 2013-09-03 | 2013-09-03 |  |  |  | PROCUREMENT>$50K 69 NO ESCALATION | -187,365.47 |  |  |  |  |  |  |  |  |  |  |  |  |  |  |  |  | 100 |  |  | ADJ |  |  |  |  |  |  |  |  |  |  |  |  |  |  |  |  |  |  |  |  |  |  |  |  |  |  |  |
| 13611065M |  | nA BPMs Comp | milestone | 0d | 2013-08-30 A | 2013-08-30 A | 13611060, 13611055a, 13611065a | 100% |  | 2014-04-07 | 2014-04-07 |  |  |  |  |  |  |  |  |  | 0 | GARZA O | 1 | 1 | M | MIKE S |  |  |  |  |  |  |  |  |  |  |  |  |  |  |  | 10-031 |  |  | 12-005 | 10-070 |  | 12-026 | OPC A |  |  |  |  |  | 6 |  |  |  |  |  |  |  |  |
| 23611014B |  | Procurement Labor - SPM BPMs ELECTRONICS FY13 |  | 43d | 2013-09-03 A | 2013-12-02 | 9-130M FS+228d | 50% | 20d | 2013-10-01 | 2013-12-02 | 99d | 23d | 8/5 M-F w/JLAB Holidays ReBaseline | ELEC ENG [25.82 h]; ELEC TECH [25.82 h] | 3,152.53 | 2,120.83 |  |  |  | 0 | GARZA O | 1 | 1 | H | MIKE S |  |  |  |  |  |  |  |  |  |  |  | APP |  |  | 3611A | 10-031 |  | 11-026 | 12-005 | 10-070 |  | 12-026 |  |  |  |  |  |  |  | 23611014B | 1527.602625 | PE | 13-015 | PR |  |  |  |
| 23611014Ba |  | Procurement Labor - SPM BPMs ELECTRONICS FY14 |  | 23.5d | 2013-09-03 A | 2013-12-02 | 23611014B FS-45d | 50% | 20d | 2013-10-01 | 2013-11-01 | 99d | 23d | 8/5 M-F w/JLAB Holidays ReBaseline | ELEC ENG [29.68 h]; ELEC TECH [29.68 h] | 3,625.13 | 2,438.77 |  |  |  | 0 | GARZA O | 1 | 1 | H | MIKE S |  |  |  |  |  |  |  |  |  |  |  | APP |  |  | 3611A | 10-031 |  | 11-026 | 12-005 | 10-070 |  | 12-026 |  |  |  |  |  |  |  | 23611014B | 1812.5661 | PE | 13-015 | PR | 14-001 |  |  |
| 23611014D5 |  | Prcrmnt - SPM BPMs ELECTRONICS (Previously Obligated) |  | 43d | 2013-09-03 A | 2013-10-21 A | 9-130M FS+228d | 100% |  | 2013-10-01 | 2013-12-02 |  |  | 8/5 M-F w/JLAB Holidays ReBaseline | PROCUREMENT<$50K 60 NO ESCALATION FY14 | 13,621.42 |  |  |  |  | 4086.426 | GARZA O | 1 | 1 | D | MIKE S |  |  |  | 0 | 13621.42 | 1362142 | 100 |  |  |  |  | APP |  |  | 3611A | 10-031 |  | 11-026 | 12-005 | 10-070 |  | 12-026 |  |  |  |  |  |  |  | 23611014D | 9534.994 |  | 13-015 | PR |  | PE | OB |
| 23611015A |  | Labor - Fab & Assy - SEE BPMs ELECTRONICS |  | 77d | 2013-09-03 A | 2014-01-30 | 23611014B FS-43d, 23611014D5 FS-43d, 23611014D FS-43d, 23611014Ba FS-43d | 66% | 54d | 2013-10-01 | 2014-01-30 | 103d | 29d | 8/5 M-F w/JLAB Holidays ReBaseline | ELEC ENG [398.4 h]; ELEC TECH [398.4 h] | 48,652.61 | 21,257.97 |  |  |  | 32110.72128 | GARZA O | 1 | 1 | U | MIKE S |  |  |  |  |  |  |  |  |  |  |  | APP |  |  |  | 10-031 |  | 11-026 | 12-005 | 10-070 |  | 12-026 |  |  |  |  |  |  |  | 23611015A |  | PE | 13-015 | PR | 14-001 |  |  |
| 23611025ca |  | System Installation Software Support - Electronics SPM BPMs Part B |  | 78d | 2013-09-03 A | 2014-04-01 | 23611025c FS-45d | 33% | 97d | 2013-12-02 | 2014-04-01 | 52d | 28d | 8/5 M-F w/JLAB Holidays ReBaseline | COMP SCIENT [267.94 h] | 18,720.97 | 5,667.33 |  |  |  | 6234.0822774 | GARZA O | 1 | 1 | S | MIKE S |  |  |  |  |  |  |  |  |  |  |  |  |  |  |  |  |  |  | 12-005 |  |  | 12-026 |  |  |  |  |  | ST |  | 23611025c |  | PE | 13-015 | PR | 14-001 |  |  |
| 23611026b |  | Hook-up & Check-out Arc 10 BPMs |  | 20d | 2013-09-03 A | 2013-09-23 A | 9-130M FS+228d | 100% |  | 2013-10-01 | 2013-10-28 |  |  | 8/5 M-F w/JLAB Holidays ReBaseline | COMP SCIENT [56 h]; ELEC TECH [56 h] | 6,544.16 | 6,342 |  |  |  | 0 | GARZA O | 1 | 1 | H | MIKE S |  |  |  |  |  |  |  | 12-035F |  |  |  |  |  |  |  | 10-031 |  | 11-026 | 12-005 | 10-070 | 12-018F |  |  |  |  |  |  |  |  | 23611026b | 6342 | PE | 13-015 | PR |  |  |  |
| 23611065a |  | System Documentation - BPMs FY13 |  | 48d | 2013-09-03 A | 2013-11-18 | 9-130M FS+228d | 50% | 12d | 2013-10-01 | 2013-12-09 | 255d | 18d | 8/5 M-F w/JLAB Holidays ReBaseline | ELEC DES [55 h] | 2,957.9 | 2,279.34 |  |  |  | 0 | GARZA O | 1 | 1 | H | MIKE S |  |  |  |  |  |  |  |  |  |  |  |  |  |  |  | 10-031 |  |  | 12-005 | 10-070 |  | 12-026 |  |  |  |  |  |  |  | 23611065a | 1433.3 | PE | 13-015 | PR |  |  |  |
| 23611065aa |  | System Documentation - BPMs FY14 |  | 28d | 2013-09-03 A | 2013-11-18 | 23611065a FS-30d | 50% | 12d | 2013-10-01 | 2013-11-07 | 255d | 234d | 8/5 M-F w/JLAB Holidays ReBaseline | ELEC DES [77 h] | 4,141.06 | 3,191.08 |  |  |  | 0 | GARZA O | 1 | 1 | H | MIKE S |  |  |  |  |  |  |  |  |  |  |  |  |  |  |  | 10-031 |  |  | 12-005 | 10-070 |  | 12-026 |  |  |  |  |  |  |  | 23611065a | 2070.53 | PE | 13-015 | PR | 14-001 |  |  |
| 23611070 |  | First Article Unit - Power Supplies/PC104/Timing Modules SPM BPMs |  | 10d | 2013-09-03 A | 2013-09-16 A | 9-130M FS+228d | 100% |  | 2013-10-01 | 2013-10-14 |  |  | 8/5 M-F w/JLAB Holidays ReBaseline | ELEC ENG [60 h]; ELEC TECH [60 h] | 7,327.2 | 7,101 |  |  |  | 0 | GARZA O | 1 | 1 | H | MIKE S |  |  |  |  |  |  |  |  |  |  |  |  |  |  |  |  |  |  | 12-005 |  |  | 12-026 |  |  |  |  |  |  |  | 23611070 | 7101 | PE | 13-015 | PR |  |  |  |
| 23611075 |  | Procurement Labor - Power Supplies/PC104/Timing Modules SPM BPMs FY13 |  | 62d | 2013-09-03 A | 2013-11-27 | 23611070 FS-10d | 50% | 19d | 2013-10-01 | 2014-01-08 | 200d | 26d | 8/5 M-F w/JLAB Holidays ReBaseline | ELEC TECH [32.26 h] | 1,515.9 | 1,036.26 |  |  |  | 734.5602 | GARZA O | 1 | 1 | H | MIKE S |  |  |  |  |  |  |  |  |  |  |  |  |  |  |  |  |  |  | 12-005 |  |  | 12-026 |  |  |  |  |  |  |  | 23611075 |  | PE | 13-015 | PR |  |  |  |
| 23611075a |  | Procurement Labor - Power Supplies/PC104/Timing Modules SPM BPMs FY14 |  | 42d | 2013-09-03 A | 2013-11-27 | 23611075 FS-45d | 50% | 19d | 2013-10-01 | 2013-11-27 | 200d | 26d | 8/5 M-F w/JLAB Holidays ReBaseline | ELEC TECH [67.75 h] | 3,183.57 | 2,176.27 |  |  |  | 1591.78625 | GARZA O | 1 | 1 | H | MIKE S |  |  |  |  |  |  |  |  |  |  |  |  |  |  |  |  |  |  | 12-005 |  |  | 12-026 |  |  |  |  |  |  |  | 23611075 |  | PE | 13-015 | PR | 14-001 |  |  |
| 23611080 |  | Procurement - Power Supplies/PC104/Timing Modules SPM BPMs |  | 62d | 2013-09-03 A | 2014-01-08 | 23611075 FS-45d, 23611075a FS-45d | 35% | 39d | 2013-10-31 | 2014-02-10 | 180d | 23d | 8/5 M-F w/JLAB Holidays ReBaseline | PROCUREMENT<$50K 60 | 20,889.06 |  |  |  |  | 2088.906 | GARZA O | 1 | 1 | D | MIKE S |  |  |  | 13577.889 | 7311.171 | 731117.1 | 100 |  |  |  |  |  |  |  |  |  |  |  | 12-005 |  |  | 12-026 |  |  |  |  |  |  |  | 23611080 | 5222.265 |  | 13-015 | PR | 14-001 | EV | OB-2 |
| 23611095 |  | Installation Labor - Power Supplies/PC104/Timing Modules SPM BPMs Part A |  | 40d | 2013-09-03 A | 2013-11-27 | 23611085a FS-77d, 23611090 FS-77d | 50% | 19d | 2013-10-03 | 2013-11-27 | 136d | 26d | 8/5 M-F w/JLAB Holidays ReBaseline | ELEC TECH [22.44 h] | 1,054.46 | 720.82 |  |  |  | 0 | GARZA O | 1 | 1 | H | MIKE S |  |  |  |  |  |  |  |  |  |  |  |  |  |  |  |  |  |  | 12-005 |  |  | 12-026 |  |  |  |  |  |  |  | 23611095 | 527.2278 | PE | 13-015 | PR | 14-001 |  |  |
| 23611095a |  | Installation Labor - Power Supplies/PC104/Timing Modules SPM BPMs Part B |  | 37d | 2013-09-03 A | 2013-11-27 | 23611095 FS-45d | 50% | 19d | 2013-12-02 | 2014-02-03 | 110d | 58d | 8/5 M-F w/JLAB Holidays ReBaseline | ELEC TECH [17.65 h] | 829.37 | 566.96 |  |  |  | 0 | GARZA O | 1 | 1 | H | MIKE S |  |  |  |  |  |  |  |  |  |  |  |  |  |  |  |  |  |  | 12-005 |  |  | 12-026 |  |  |  |  |  |  |  | 23611095 | 414.68675 | PE | 13-015 | PR | 14-001 |  |  |
| 23611913LOE |  | FY13 Mngmnt Effort for BPMs |  | 20d | 2013-09-03 A | 2013-09-30 A | 9-130M FS+228d | 100% |  | 2013-10-01 | 2013-10-28 |  |  | 8/5 M-F w/JLAB Holidays ReBaseline | SCIENTIST [10.73 h] | 806.68 | 781.79 | 100 | 100 |  | 0 | GARZA O | 1 | 1 | E | MIKE S |  |  |  |  |  |  |  |  |  |  |  |  |  |  |  |  |  |  |  |  |  |  |  |  |  |  |  |  |  | 23611913LOE | 781.7878 | PE |  | PR |  |  |  |

Notes:
- 1356018: Corrective Actions: Add pred to Mark's procurement / Stands
- 13611026: Entry Criteria: Ext Pred: Girders, beamline, / IOCs, network installed
- 13611026a: Entry Criteria: Ext Pred: Girders, beamline, / IOCs, network installed
- 13611065: Entry Criteria: Ext Pred: Vacuum
- 13611026b: Entry Criteria: Ext Pred: Girders, beamline, / IOCs, network installed
- 13611025b: Entry Criteria: Ext Pred: Girders, beamline, / IOCs, network installed
- 13611065a: Entry Criteria: Ext Pred: Vacuum
- 13611070: Entry Criteria: Ext Pred: Girders, beamline, / IOCs, network installed
- 13611075: Entry Criteria: Ext Pred: Girders, beamline, / IOCs, network installed
- 13611080: Entry Criteria: Ext Pred: Girders, beamline, / IOCs, network installed
- 13611025: Entry Criteria: Ext Pred: Girders, beamline, / IOCs, network installed
- 13611036: Entry Criteria: Ext Pred: Girders, beamline, / IOCs, network installed
- 13611025c: Entry Criteria: Ext Pred: Girders, beamline, / IOCs, network installed
- 13611085: Entry Criteria: Ext Pred: Girders, beamline, / IOCs, network installed
- 13611037: Entry Criteria: Ext Pred: Girders, beamline, / IOCs, network installed
- 13611037a: Entry Criteria: Ext Pred: Girders, beamline, / IOCs, network installed
- 13611038: Entry Criteria: Ext Pred: Girders, beamline, / IOCs, network installed
- 13611038a: Entry Criteria: Ext Pred: Girders, beamline, / IOCs, network installed
- 13611038b: Entry Criteria: Ext Pred: Girders, beamline, / IOCs, network installed
- 13611039: Entry Criteria: Ext Pred: Girders, beamline, / IOCs, network installed
- 13611045: Steps: Assembly Electronics Labor - nA BPM Sys (done)
- 13611050: Steps: Assembly & Testing Procurement - nA BPM Sys (done)
- 13611055: Entry Criteria: Ext Pred: Girders, beamline, / IOCs, network installed
- 13611055a: Entry Criteria: Ext Pred: Girders, beamline, / IOCs, network installed
- 13611060: Entry Criteria: Ext Pred: Vacuum / Steps: Software support - nA BPMs (done)
- 23611015A: Steps: Assembly; Testing
- 23611025ca: Entry Criteria: Ext Pred: Girders, beamline, / IOCs, network installed / Steps: Rev 1 (done); Rev 2
- 23611026b: Entry Criteria: Ext Pred: Girders, beamline, / IOCs, network installed
- 23611065a: Entry Criteria: Ext Pred: Vacuum
- 23611065aa: Entry Criteria: Ext Pred: Vacuum
- 23611070: Entry Criteria: Ext Pred: Girders, beamline, / IOCs, network installed
- 23611075: Entry Criteria: Ext Pred: Girders, beamline, / IOCs, network installed / Steps: 0-100
- 23611075a: Entry Criteria: Ext Pred: Girders, beamline, / IOCs, network installed
- 23611080: Entry Criteria: Ext Pred: Girders, beamline, / IOCs, network installed
- 23611095: Entry Criteria: Ext Pred: Girders, beamline, / IOCs, network installed
- 23611095a: Entry Criteria: Ext Pred: Girders, beamline, / IOCs, network installed

| ID | Activity | Type | Duration | Start | Finish | Predecessors | Complete | Remaining | Planned start | Planned finish | Total float | Free float | Calendar | Resources | Cost | Actual cost | Original Activity ID Rebaseline | Remaining Material Cost Based on % Compl | Claimed Material Cost Based on % Complet | Initial Claimed Material Calc | Claimed Material Divider | MONTHLY EV COST | PRIOR MONTH EV COST | RESP - Responsibility | STRT%COMP for CM EVM | FNSH%COMP for CM EVM | Advance Purchase Plan > 500K | EVMS Reporting Codes | CAM RESPONSIBLE | CR 10-031 | CR 10-070 | CR 11-026 | CR 12-005 | CR 12-026 | BOE Procurement | CR 13-015 | Post Rebaseline | Obligated Prior to Rebaseline | CR 14-001 | CR 08-016 | CR 08-040 | CR 08-051 | CR 09-012 | BOE Labor | BOE Expenses | 12 GEV MAJOR PROCUREMENT CATAGORY | Activities with Steps | LOE % Pre Calc | LOE % | LOE Divider | LOE Multiplier | BOE NOTES | BOE Adder | Milestone Level |
| --- | --- | --- | --- | --- | --- | --- | --- | --- | --- | --- | --- | --- | --- | --- | --- | --- | --- | --- | --- | --- | --- | --- | --- | --- | --- | --- | --- | --- | --- | --- | --- | --- | --- | --- | --- | --- | --- | --- | --- | --- | --- | --- | --- | --- | --- | --- | --- | --- | --- | --- | --- | --- | --- | --- |
| 23611015B | Procrmnt - Fab/Assy & Testing - SPM BPMs ELECTRONICS |  | 20d | 2013-09-09 A | 2013-12-02 | 23611014D5 FS-25d, 23611014Ba FS-45d, 23611014D FS-45d, 23611014B FS-45d, 23611015A FS-83d | 35% | 20d | 2013-11-01 | 2013-12-02 | 74d | 25d | 8/5 M-F w/JLAB Holidays ReBaseline | PROCUREMENT<$50K 60 | 55,902.92 |  | 23611015B | 36336.898 | 19566.022 | 1956602.2 | 100 | 5590.292 | 13975.73 | GARZA O | 1 | 1 | APP | D | MIKE S | 10-031 | 10-070 | 11-026 | 12-005 | 12-026 | EV | 13-015 | PR | OB-2 | 14-001 |  |  |  |  |  |  |  |  |  |  |  |  |  |  |  |
| 23611025 | System Installation - Electronics SPM BPMs Part A |  | 19d | 2013-09-09 A | 2013-11-27 | 23611015B FS-45d | 50% | 19d | 2013-11-01 | 2013-11-27 | 52d | 0d | 8/5 M-F w/JLAB Holidays ReBaseline | ELEC TECH [48.36 h] | 2,272.44 | 1,508.67 | 23611025 |  |  |  |  | 0 | 1136.2182 | GARZA O | 1 | 1 | APP | H | MIKE S | 10-031 | 10-070 | 11-026 | 12-005 | 12-026 |  | 13-015 | PR |  | 14-001 | 08-016 | 08-040 | 08-051 | 09-012 | PE |  |  |  |  |  |  |  |  |  |  |
| 23611025b | System Installation Contract Labor - Electronics SPM BPMs |  | 20d | 2013-09-09 A | 2013-12-02 | 23611015B FS-45d | 10% | 20d | 2013-11-01 | 2013-12-02 | 49d | 25d | 8/5 M-F w/JLAB Holidays ReBaseline | SUPPLIES & MATERIALS | 17,303.29 |  | 23611025a5 |  |  |  |  | 0 | 1730.329 | GARZA O | 1 | 1 |  | U | MIKE S |  |  |  | 12-005 | 12-026 |  | 13-015 | PR |  | 14-001 |  |  |  |  |  | PE |  |  |  |  |  |  |  |  |  |
| 23611025c | System Installation Software Support - Electronics SPM BPMs Part A |  | 19d | 2013-09-09 A | 2013-11-27 | 23611015B FS-45d | 50% | 19d | 2013-11-01 | 2013-11-27 | 78d | 26d | 8/5 M-F w/JLAB Holidays ReBaseline | COMP SCIENT [76.78 h] | 5,364.62 | 3,561.49 | 23611025c |  |  |  |  | 0 | 2682.3093 | GARZA O | 1 | 1 |  | H | MIKE S |  |  |  | 12-005 | 12-026 |  | 13-015 | PR |  | 14-001 |  |  |  |  | PE |  |  |  |  |  |  |  |  |  |  |
| 23611027 | Hook-up & Check-out H-D B/L BPMs |  | 15d | 2013-09-09 A | 2014-04-01 | 23611025ca FS-125d, 23611100 FS-105d, 23611025b FS-45d, 23611025a FS-105d, 23458065a FS-20d, 23458065 FS-20d | 50% | 97d | 2014-03-12 | 2014-04-01 | 24d | 0d | 8/5 M-F w/JLAB Holidays ReBaseline | COMP SCIENT [68 h]; ELEC TECH [68 h] | 7,946.48 | 2,249.9 | 23611027 |  |  |  |  | 0 | 3973.24 | GARZA O | 1 | 1 |  | H | MIKE S | 10-031 | 10-070 | 11-026 | 12-005 | 12-026 |  | 13-015 | PR |  | 14-001 |  |  |  |  | PE |  |  |  |  |  |  |  |  |  |  |
| 23611014D | Prcrmnt - SPM BPMs ELECTRONICS |  | 43d | 2013-09-16 A | 2013-12-02 | 9-140M | 25% | 20d | 2013-10-01 | 2013-12-02 | 99d | 23d | 8/5 M-F w/JLAB Holidays ReBaseline | PROCUREMENT<$50K 60 | 36,269.15 |  | 23611014D | 27201.8625 | 9067.2875 | 906728.75 | 100 | 0 | 9067.2875 | GARZA O | 1 | 1 | APP | D | MIKE S | 10-031 | 10-070 | 11-026 | 12-005 | 12-026 | PE | 13-015 | PR | OB-2 | 14-001 |  |  |  |  |  |  | 3611A |  |  |  |  |  |  |  |  |
| 23611085 | Assembly Labor - Power Supplies/PC104/Timing Modules SPM BPMs Part A |  | 40d | 2013-09-16 A | 2013-11-27 | 23611075 FS-62d, 23611080 FS-62d, 23611075a FS-62d |  | 19d | 2013-10-03 | 2013-11-27 | 157d | 0d | 8/5 M-F w/JLAB Holidays ReBaseline | ELEC TECH [332.47 h] | 15,622.77 | 9,922.1 | 23611085 |  |  |  |  | 0 |  | GARZA O | 1 | 1 |  | S | MIKE S |  |  |  | 12-005 | 12-026 |  | 13-015 | PR |  | 14-001 |  |  |  |  | PE |  |  | ST |  |  |  |  |  |  |  |
| 23611090 | Assembly Procurement - Power Supplies/PC104/Timing Modules SPM BPMs |  | 77d | 2013-09-16 A | 2014-01-30 | 23611075a FS-62d, 23611075 FS-62d, 23611080 FS-62d | 25% | 54d | 2013-10-03 | 2014-02-03 | 159d | 23d | 8/5 M-F w/JLAB Holidays ReBaseline | PROCUREMENT<$50K 60 | 1,703.71 |  | 23611090 | 1277.7825 | 425.9275 | 42592.75 | 100 | 0 | 425.9275 | GARZA O | 1 | 1 |  | D | MIKE S |  |  |  | 12-005 | 12-026 | EV | 13-015 | PR | OB-2 | 14-001 |  |  |  |  |  |  |  |  |  |  |  |  |  |  |  |
| 23611914LOE | FY14 Mngmnt Effort for BPMs Part A |  | 42d | 2013-10-01 A | 2013-11-27 | 23611913LOE | 55% | 19d | 2013-11-01 | 2014-01-13 | 67d | 0d | 8/5 M-F w/JLAB Holidays ReBaseline | SCIENTIST [15.07 h] | 1,132.96 | 620.43 | 23611914LOE |  |  |  |  | 620.41031976 |  | GARZA O | 1 | 1 |  | E | MIKE S |  |  |  |  |  |  |  | PR |  | 14-001 |  |  |  |  | PE |  |  |  | 45.23809523 | 54.76190476 | 100 | 100 |  |  |  |
| 23611100 | Installation Procurement - Power Supplies/PC104/Timing Modules SPM BPMs |  | 77d | 2013-11-01 | 2014-03-04 | 23611095a FS-77d |  |  |  |  | 52d | 28d | 8/5 M-F w/JLAB Holidays ReBaseline | PROCUREMENT<$50K 60 | 1,916.67 |  | 23611100 | 1916.67 | 0 | 0 | 100 | 0 |  | GARZA O | 1 | 1 |  | D | MIKE S |  |  |  | 12-005 | 12-026 | EV | 13-015 | PR |  | 14-001 |  |  |  |  |  |  |  |  |  |  |  |  |  |  |  |
| 23611025a | System Installation - Electronics SPM BPMs Part B |  | 58d | 2013-12-02 | 2014-03-04 | 23611025 |  |  |  |  | 52d | 28d | 8/5 M-F w/JLAB Holidays ReBaseline | ELEC TECH [125.49 h] | 5,896.78 |  | 23611025 |  |  |  |  | 0 |  | GARZA O | 1 | 1 | APP | H | MIKE S | 10-031 | 10-070 | 11-026 | 12-005 | 12-026 |  | 13-015 | PR |  | 14-001 | 08-016 | 08-040 | 08-051 | 09-012 | PE |  |  |  |  |  |  |  |  |  |  |
| 23611085a | Assembly Labor - Power Supplies/PC104/Timing Modules SPM BPMs Part b |  | 37d | 2013-12-02 | 2014-02-03 | 23611085 |  |  |  |  | 157d | 21d | 8/5 M-F w/JLAB Holidays ReBaseline | ELEC TECH [261.41 h] | 12,283.66 |  | 23611085 |  |  |  |  | 0 |  | GARZA O | 1 | 1 |  | S | MIKE S |  |  |  | 12-005 | 12-026 |  | 13-015 | PR |  | 14-001 |  |  |  |  | PE |  |  |  |  |  |  |  |  |  |  |
| 23611914LOEa | FY14 Mngmnt Effort for BPMs Part B |  | 181d | 2013-12-02 | 2014-08-26 | 23611914LOE |  |  |  |  | 67d | 46d | 8/5 M-F w/JLAB Holidays ReBaseline | SCIENTIST [55.17 h] | 4,147.68 |  | 23611914LOE |  |  |  |  | 0 |  | GARZA O | 1 | 1 |  | E | MIKE S |  |  |  |  |  |  |  | PR |  | 14-001 |  |  |  |  | PE |  |  |  | 100 | 0 | 100 | 100 |  |  |  |
| 23611036 | First Article Cavities - nA BPM Sys |  | 39d | 2014-01-03 | 2014-02-27 | 9-140M FS+60d |  |  |  |  | 25d | 0d | 8/5 M-F w/JLAB Holidays ReBaseline | MECH ENG [272 h]; ELEC ENG [265.2 h] | 40,234.72 |  | 23611036 |  |  |  |  | 0 |  | GARZA O | 1 | 1 |  |  | MIKE S |  |  |  | 12-005 | 12-026 | EJ | 13-015 | PR |  | 14-001 |  |  |  |  | PE | EJ |  |  |  |  |  |  | Cost of materials has increased |  |  |
| 23611065a5 | System Documentation - nA BPMs |  | 167d | 2014-03-04 | 2014-10-27 | 23611035M FS-21d |  |  |  |  | 24d | 3d | 8/5 M-F w/JLAB Holidays ReBaseline | ELEC DES [175.44 h] | 9,435.16 |  | 23611065a5 |  |  |  |  | 0 |  | GARZA O | 1 | 1 |  |  | MIKE S | 10-031 | 10-070 |  | 12-005 | 12-026 |  | 13-015 | PR |  | 14-001 |  |  |  |  | PE |  |  |  |  |  |  |  |  |  |  |
| 23611037 | Procurement Labor Cavities - nA BPM Sys |  | 82d | 2014-03-27 | 2014-07-22 | 23611036 FS+19d |  |  |  |  | 25d | 0d | 8/5 M-F w/JLAB Holidays ReBaseline | MECH TECH [68 h]; ELEC TECH [68 h] | 6,413.08 |  | 23611037 |  |  |  |  | 0 |  | GARZA O | 1 | 1 |  |  | MIKE S |  |  |  | 12-005 | 12-026 | EJ | 13-015 | PR |  | 14-001 |  |  |  |  | PE | EJ |  |  |  |  |  |  | Additional design manpower required or unknown at this time' | NO |  |
| 23611037a | Procurement Cavities - nA BPM Sys |  | 82d | 2014-03-27 | 2014-07-22 | 23611036 FS-1d, 23611037 FS-82d |  |  |  |  | 25d | 4d | 8/5 M-F w/JLAB Holidays ReBaseline | PROCUREMENT<$50K 60 | 180,870.59 |  | 23611037a | 180870.59 | 0 | 0 | 100 | 0 |  | GARZA O | 1 | 1 |  |  | MIKE S |  |  |  | 12-005 | 12-026 | EJ | 13-015 | PR |  | 14-001 |  |  |  |  | PE | EJ |  |  |  |  |  |  | Higher material costs |  |  |
| 23611038 | First Article Unit RF Receiver - nA BPM Sys |  | 49d | 2014-03-28 | 2014-06-05 | 9-140M FS+118d |  |  |  |  | 87d | 0d | 8/5 M-F w/JLAB Holidays ReBaseline | ELEC ENG [245 h] | 18,406.85 |  | 23611038 |  |  |  |  | 0 |  | GARZA O | 1 | 1 |  |  | MIKE S |  |  |  | 12-005 | 12-026 |  | 13-015 | PR |  | 14-001 |  |  |  |  | PE |  |  |  |  |  |  |  |  |  |  |
| 23611038a | First Article Unit Digital IF - nA BPM Sys |  | 29d | 2014-03-28 | 2014-05-07 | 9-140M FS+118d |  |  |  |  | 87d | 0d | 8/5 M-F w/JLAB Holidays ReBaseline | ELEC ENG [164.33 h] | 12,346.11 |  | 23611038a |  |  |  |  | 0 |  | GARZA O | 1 | 1 |  |  | MIKE S |  |  |  | 12-005 | 12-026 |  | 13-015 | PR |  | 14-001 |  |  |  |  | PE |  |  |  |  |  |  |  |  |  |  |
| 23611038b | First Article Enclosure nA Receiver - nA BPM Sys |  | 19d | 2014-03-28 | 2014-04-23 | 23611038a FS-29d, 23611038 FS-49d |  |  |  |  | 87d | 66d | 8/5 M-F w/JLAB Holidays ReBaseline | ELEC ENG [68 h]; ELEC TECH [129.2 h] | 11,179.95 |  | 23611038b |  |  |  |  | 0 |  | GARZA O | 1 | 1 |  |  | MIKE S |  |  |  | 12-005 | 12-026 |  | 13-015 | PR |  | 14-001 |  |  |  |  | PE |  |  |  |  |  |  |  |  |  |  |
| 23611060 | Software support - nA BPMs |  | 107d | 2014-03-28 | 2014-08-27 | 23611050 FS-147d, 23611055 FS-160d |  |  |  |  | 66d | 45d | 8/5 M-F w/JLAB Holidays ReBaseline | COMP SCIENT [544 h] | 38,009.28 |  | 23611060 |  |  |  |  | 0 |  | GARZA O | 1 | 1 |  |  | MIKE S | 10-031 | 10-070 |  | 12-005 | 12-026 |  | 13-015 | PR |  | 14-001 |  |  |  |  | PE |  |  |  |  |  |  |  |  |  |  |
| 23611035M | SPM BPMs Comp | milestone | 0d | 2014-04-01 | 2014-04-01 | 23611027 |  |  |  |  | 24d | 0d | 8/5 M-F w/JLAB Holidays ReBaseline |  |  |  | 23611035M |  |  |  |  | 0 |  | GARZA O | 1 | 1 |  | M | MIKE S |  | 10-070 | 11-026 | 12-005 | 12-026 |  | 13-015 | PR |  |  |  |  |  |  |  |  |  |  |  |  |  |  |  |  | 6 |
| 23611039 | Procurement Labor Electronics - nA BPM Sys |  | 19d | 2014-04-30 | 2014-05-27 | 9-140M FS+141d |  |  |  |  | 21d | 0d | 8/5 M-F w/JLAB Holidays ReBaseline | ELEC TECH [129.2 h]; ELEC ENG [51 h] | 9,902.74 |  | 23611039 |  |  |  |  | 0 |  | GARZA O | 1 | 1 |  |  | MIKE S |  |  |  | 12-005 | 12-026 |  | 13-015 | PR |  | 14-001 |  |  |  |  | PE |  |  |  |  |  |  |  |  |  |  |
| 23611040 | Procurements Electronics - nA BPM Sys |  | 19d | 2014-04-30 | 2014-05-27 | 23611039 FS-19d |  |  |  |  | 21d | 0d | 8/5 M-F w/JLAB Holidays ReBaseline | PROCUREMENT<$50K 60 | 35,751.25 |  | 23611040 | 35751.25 | 0 | 0 | 100 | 0 |  | GARZA O | 1 | 1 | APP |  | MIKE S |  | 10-070 |  | 12-005 | 12-026 | EV | 13-015 | PR |  | 14-001 |  |  |  |  |  |  |  |  |  |  |  |  |  |  |  |
| 23611045 | Assembly Electronics Labor - nA BPM Sys |  | 83d | 2014-06-27 | 2014-10-23 | 23611040 FS+22d |  |  |  |  | 21d | 0d | 8/5 M-F w/JLAB Holidays ReBaseline | ELEC TECH [340 h]; ELEC ENG [68 h] | 21,085.44 |  | 23611045 |  |  |  |  | 0 |  | GARZA O | 1 | 1 | APP |  | MIKE S |  | 10-070 |  | 12-005 | 12-026 |  | 13-015 | PR |  | 14-001 |  |  |  |  | PE |  |  |  |  |  |  |  |  |  |  |
| 23611050 | Assembly & Testing Procurement - nA BPM Sys |  | 83d | 2014-06-27 | 2014-10-23 | 23611045 FS-83d, 23611040 FS-1d |  |  |  |  | 21d | 0d | 8/5 M-F w/JLAB Holidays ReBaseline | PROCUREMENT<$50K 60 NO ESCALATION FY15 | 7,240.76 |  | 23611050 | 7240.76 | 0 | 0 | 100 | 0 |  | GARZA O | 1 | 1 |  |  | MIKE S |  | 10-070 |  | 12-005 | 12-026 | PE | 13-015 | PR |  | 14-001 |  |  |  |  | PE |  |  |  |  |  |  |  |  |  |  |
| 23611055 | System Installation Electronics - nA BPM Sytem (BPM) |  | 67d | 2014-07-29 | 2014-10-30 | 23611050 FS-62d, 23611038b, 23611037a, 23458065, 23458065a |  |  |  |  | 21d | 0d | 8/5 M-F w/JLAB Holidays ReBaseline | ELEC TECH [170 h] | 7,988.3 |  | 23611055 |  |  |  |  | 0 |  | GARZA O | 1 | 1 | APP |  | MIKE S | 10-031 | 10-070 |  | 12-005 | 12-026 |  | 13-015 | PR |  | 14-001 | 08-016 |  |  | 09-012 | PE |  |  |  |  |  |  |  |  |  |  |
| 23611055a | System Installation Electronics Contract Labor - nA BPM Sytem (BPM) |  | 67d | 2014-07-29 | 2014-10-30 | 23611037a, 23611038b, 23611055 FS-67d |  |  |  |  | 21d | 0d | 8/5 M-F w/JLAB Holidays ReBaseline | PROCUREMENT<$50K 60 NO ESCALATION FY15 | 14,481.52 |  | 23611055a | 14481.52 | 0 | 0 | 100 | 0 |  | GARZA O | 1 | 1 | APP |  | MIKE S |  |  |  | 12-005 | 12-026 | PE | 13-015 | PR |  | 14-001 |  |  |  |  |  |  |  |  |  |  |  |  |  |  |  |
| 23611065M | nA BPMs Comp | milestone | 0d | 2014-10-30 | 2014-10-30 | 23611065a5, 23611055a, 23611065a, 23611065aa, 23611060, 23611914LOEa |  |  |  |  | 21d | 13d | 8/5 M-F w/JLAB Holidays ReBaseline |  |  |  | 23611065M |  |  |  |  | 0 |  | GARZA O | 1 | 1 |  | M | MIKE S | 10-031 | 10-070 |  | 12-005 | 12-026 |  | 13-015 | PR |  |  |  |  |  |  |  |  |  |  |  |  |  |  |  |  | 6 |

Notes:
- 23611025: Entry Criteria: Ext Pred: Girders, beamline, / IOCs, network installed
- 23611025b: Entry Criteria: Ext Pred: Girders, beamline, / IOCs, network installed
- 23611025c: Entry Criteria: Ext Pred: Girders, beamline, / IOCs, network installed
- 23611027: Entry Criteria: Ext Pred: Girders, beamline, / IOCs, network installed
- 23611085: Entry Criteria: Ext Pred: Girders, beamline, / IOCs, network installed / Steps: Chassis Assembly; Media Converter Interface
- 23611090: Entry Criteria: Ext Pred: Girders, beamline, / IOCs, network installed
- 23611100: Entry Criteria: Ext Pred: Girders, beamline, / IOCs, network installed
- 23611025a: Entry Criteria: Ext Pred: Girders, beamline, / IOCs, network installed
- 23611085a: Entry Criteria: Ext Pred: Girders, beamline, / IOCs, network installed
- 23611036: Entry Criteria: Ext Pred: Girders, beamline, / IOCs, network installed
- 23611065a5: Entry Criteria: Ext Pred: Vacuum
- 23611037: Entry Criteria: Ext Pred: Girders, beamline, / IOCs, network installed
- 23611037a: Entry Criteria: Ext Pred: Girders, beamline, / IOCs, network installed
- 23611038: Entry Criteria: Ext Pred: Girders, beamline, / IOCs, network installed
- 23611038a: Entry Criteria: Ext Pred: Girders, beamline, / IOCs, network installed
- 23611038b: Entry Criteria: Ext Pred: Girders, beamline, / IOCs, network installed
- 23611060: Entry Criteria: Ext Pred: Vacuum
- 23611039: Entry Criteria: Ext Pred: Girders, beamline, / IOCs, network installed
- 23611055: Entry Criteria: Ext Pred: Girders, beamline, / IOCs, network installed
- 23611055a: Entry Criteria: Ext Pred: Girders, beamline, / IOCs, network installed

| ID | WBS | Activity | Type | Duration | Start | Finish | Predecessors | Complete | Remaining | Planned start | Planned finish | Total float | Free float | Calendar | Resources | Cost | Actual cost | LOE Divider | LOE Multiplier | Calculated Remaining Total Cost | MONTHLY EV COST | RESP - Responsibility | STRT%COMP for CM EVM | FNSH%COMP for CM EVM | EVMS Reporting Codes | CAM RESPONSIBLE | CR 08-058 | LOE % Pre Calc | LOE % | CR 07-024 | CR 09-035 | CR 10-070 | Remaining Material Cost Based on % Compl | Claimed Material Cost Based on % Complet | Initial Claimed Material Calc | Claimed Material Divider | Installation | OPC Allison | CR 12-053 | CR 08-016 | CR 09-012 | CR 10-031 | ReBaseline Actuals Adjustment | Milestone Level | Original Activity ID Rebaseline | PRIOR MONTH EV COST | Activities with Steps | BOE Procurement | BOE Labor | BOE Expenses | CR 13-015 | Post Rebaseline | Obligated Prior to Rebaseline | CR 14-001 |
| --- | --- | --- | --- | --- | --- | --- | --- | --- | --- | --- | --- | --- | --- | --- | --- | --- | --- | --- | --- | --- | --- | --- | --- | --- | --- | --- | --- | --- | --- | --- | --- | --- | --- | --- | --- | --- | --- | --- | --- | --- | --- | --- | --- | --- | --- | --- | --- | --- | --- | --- | --- | --- | --- | --- |
|  | 2 | **1.3.6.1.2 HARPS** |  |  | 2009-01-02 | 2013-09-30 |  |  |  |  |  |  |  |  |  |  |  |  |  |  |  |  |  |  |  |  |  |  |  |  |  |  |  |  |  |  |  |  |  |  |  |  |  |  |  |  |  |  |  |  |  |  |  |  |
| 13612909LOE |  | FY09 Mngmnt Effort for Harps |  | 189d | 2009-01-02 A | 2009-09-30 A | 13612909LOEX | 100% |  |  |  |  |  |  | SR STAFF [24.39 h] | 2,508.27 | 2,508.27 | 100 | 100 | 0 | 2508.2676 | GARZA O | 1 | 1 | E | MIKE S | 08-058 |  |  |  |  |  |  |  |  |  |  |  |  |  |  |  |  |  |  |  |  |  |  |  |  |  |  |  |
| 13612910LOE |  | FY10 Mngmnt Effort for Harps |  | 248d | 2009-10-01 A | 2010-09-30 A | 13612909LOE | 100% |  |  |  |  |  |  | SR STAFF [32 h] | 3,395.84 | 3,395.84 | 100 | 100 | 0 | 3395.84 | GARZA O | 1 | 1 | E | MIKE S |  |  |  |  |  |  |  |  |  |  |  |  |  |  |  |  |  |  |  |  |  |  |  |  |  |  |  |  |
| 13612911LOE |  | FY11 Mngmnt Effort for Harps |  | 248d | 2010-10-01 A | 2011-09-30 A | 13612910LOE | 100% |  |  |  |  |  |  | SR STAFF [32 h] | 3,504.32 | 3,504.32 | 100 | 100 | 0 | 3504.32 | GARZA O | 1 | 1 | E | MIKE S |  | 8.46774193 | 91.53225806 |  |  |  |  |  |  |  |  |  |  |  |  |  |  |  |  |  |  |  |  |  |  |  |  |  |
| 13612011 |  | LABOR Prep for Harp Sys Procuremnts (prior to 6 mon down) |  | 169d | 2011-10-03 A | 2012-06-11 A | 9-120M, 121612030, 121612035 | 100% |  |  |  |  |  |  | ELEC ENG [40 h]; ELEC TECH [40 h] | 4,587.6 | 4,587.6 |  |  | 0 | 4587.6 | GARZA O | 1 | 1 | H | MIKE S |  |  |  | 07-024 | 09-035 | 10-070 |  |  |  |  |  |  |  |  |  |  |  |  |  |  |  |  |  |  |  |  |  |  |
| 13612912LOE |  | FY12 Mngmnt Effort for Harps |  | 247d | 2011-10-03 A | 2012-09-28 A | 13612911LOE | 100% |  |  |  |  |  |  | SR STAFF [32 h] | 3,616 | 3,616 | 100 | 100 | 0 | 3616 | GARZA O | 1 | 1 | E | MIKE S |  | 7.69230769 | 92.3076923 |  |  |  |  |  |  |  |  |  |  |  |  |  |  |  |  |  |  |  |  |  |  |  |  |  |
| 13612014 |  | Vendors Fab Harp Sys Pieces & Components (spanning 6 month down) |  | 161d | 2012-01-03 A | 2012-08-20 A | 13612011 FS-50d | 100% |  |  |  |  |  |  | PROCUREMENT<$50K 60 | 162,630.82 |  |  |  | 0 | 162630.82 | GARZA O | 1 | 1 | D | MIKE S |  |  |  |  | 09-035 | 10-070 | 0 | 162630.82 | 16263082 | 100 |  |  |  |  |  |  |  |  |  |  |  |  |  |  |  |  |  |  |
| 13612015 |  | Harp Sys Fab & Assy |  | 84d | 2012-04-16 A | 2012-08-13 A | 13612014 FS-25d | 100% |  |  |  |  |  |  | ELEC ENG [60 h]; SCIENTIST [120 h]; SUPPLIES & MATERIALS; ELEC DES [40 h]; MECH TECH [40 h]; ELEC TECH [320 h] | 33,645.02 | 30,626.4 |  |  | 0 | 33645.02 | GARZA O | 1 | 1 | H | MIKE S |  |  |  |  |  | 10-070 |  |  |  |  | Install |  |  |  |  |  |  |  |  |  |  |  |  |  |  |  |  |  |
| 13612020 |  | Harp Component Testing FY12 |  | 127d | 2012-07-02 A | 2012-12-17 A | 9-120M, 13612015 FS-80d | 100% |  | 2012-07-02 | 2013-01-07 |  |  |  | ELEC TECH [92.57 h]; COMP SCIENT [61.71 h]; ELEC ENG [30.86 h] | 10,475.18 | 10,461.28 |  |  | 0 | 10312.0059 | GARZA O | 1 | 1 | H | MIKE S |  |  |  |  |  | 10-070 |  |  |  |  |  | OPC A | 12-053 |  |  |  |  |  |  |  |  |  |  |  |  |  |  |  |
| 13612020a |  | Harp Component Testing FY13 |  | 127d | 2012-07-02 A | 2012-12-17 A | 13612020 FS-85d | 100% |  | 2012-07-02 | 2013-01-07 |  |  |  | COMP SCIENT [18.29 h]; ELEC TECH [27.43 h]; ELEC ENG [9.14 h] | 3,103.94 | 3,100.2 |  |  | 0 | 3153.0615 | GARZA O | 1 | 1 | H | MIKE S |  |  |  |  |  | 10-070 |  |  |  |  |  |  | 12-053 |  |  |  |  |  |  |  |  |  |  |  |  |  |  |  |
| 13612020b |  | Harp Component Testing Procurement |  | 95d | 2012-07-02 A | 2012-11-12 A | 13612015 FS-100d, 9-120M | 100% |  |  |  |  |  |  | PROCUREMENT<$50K 60 NO ESCALATION FY13 | 2,340.02 |  |  |  | 0 | 2340.02 | GARZA O | 1 | 1 | H | MIKE S |  |  |  |  |  | 10-070 | 0 | 2340.02 | 234002 | 100 |  |  | 12-053 |  |  |  |  |  |  |  |  |  |  |  |  |  |  |  |
| 13612913LOE |  | FY13 Mngmnt Effort for Harps |  | 248d | 2012-10-01 A | 2013-08-30 A | 13612912LOE | 100% |  | 2012-10-01 | 2013-09-30 |  |  |  | SR STAFF [29.42 h] | 3,430.37 | 3,434.78 | 100 | 100 | 632.06528 | 3430.372 | GARZA O | 1 | 1 | E | MIKE S |  | 8.06451612 | 91.93548387 |  |  |  |  |  |  |  |  | OPC A |  |  |  |  |  |  |  |  |  |  |  |  |  |  |  |  |
| 13612025 |  | Harp Sys Implementn |  | 73d | 2012-10-15 A | 2013-04-15 A | 2-02M, 13612020b FS-100d, 13612020a FS-100d, 1362025 | 100% |  | 2012-10-15 | 2013-02-05 |  |  |  | PROCUREMENT<$50K 60; ELEC TECH [360 h]; SUPPLIES & MATERIALS; ELEC DES [40 h]; ELEC ENG [40 h]; MECH TECH [40 h] | 34,912.94 | 23,226 |  |  | 0 | 34912.94 | GARZA O | 1 | 1 | H | MIKE S |  |  |  |  |  | 10-070 | 0 | 8451.3 | 845130 | 100 |  | OPC A |  | 08-016 | 09-012 | 10-031 |  |  |  |  |  |  |  |  |  |  |  |  |
| 13612030 |  | Harp Systems Software Implementn & Cmmssng FY12 |  | 2d | 2013-01-21 A | 2013-08-30 A | 13612025 FS-30d | 100% |  | 2013-05-07 | 2013-05-08 |  |  |  | COMP SCIENT [5.33 h]; ELEC ENG [0.89 h]; ELEC TECH [0.89 h]; SCIENTIST [2.67 h] | 660.76 | 660.76 |  |  | 320.1787 | 640.3574 | GARZA O | 1 | 1 | H | MIKE S |  |  |  |  |  | 10-070 |  |  |  |  |  | OPC A | 12-053 |  |  |  |  |  |  |  |  |  |  |  |  |  |  |  |
| 13612035 |  | Harp Systems Software Implementn & Cmmssng FY13 |  | 88d | 2013-01-21 A | 2013-08-30 A | 13612030 FS-70d | 100% |  | 2013-05-09 | 2013-09-12 |  |  |  | COMP SCIENT [234.67 h]; ELEC ENG [39.11 h]; ELEC TECH [39.11 h]; SCIENTIST [117.33 h] | 29,066.84 | 29,066.84 |  |  | 14533.419 | 29066.838 | GARZA O | 1 | 1 | H | MIKE S |  |  |  |  |  | 10-070 |  |  |  |  |  |  | 12-053 |  |  |  |  |  |  |  |  |  |  |  |  |  |  |  |
| 13612950 |  | Re-Baseline Actuals Adjustment |  | 1d | 2013-08-30 A | 2013-08-30 A |  | 100% |  | 2013-09-03 | 2013-09-03 |  |  |  | PROCUREMENT>$50K 69 NO ESCALATION | 93,141.43 |  |  |  |  | 93141.43 |  |  |  |  |  |  |  |  |  |  |  | 0 | 93141.43 | 9314143 | 100 |  |  |  |  |  |  | ADJ |  |  |  |  |  |  |  |  |  |  |  |
| 13612035M |  | Harp Sys Comp | milestone | 0d | 2013-08-30 A | 2013-08-30 A | 13612035, 13612030 | 100% |  | 2013-09-23 | 2013-09-23 |  |  |  |  |  |  |  |  |  | 0 | GARZA O | 1 | 1 | M | MIKE S |  |  |  |  |  | 10-070 |  |  |  |  |  | OPC A |  |  |  |  |  | 6 |  |  |  |  |  |  |  |  |  |  |
| 23612030 |  | Harp Sys Implementn Labor |  | 20d | 2013-09-03 A | 2013-09-23 A | 23458065 FS-26d, 9-130M FS+228d, 23458065a FS-26d | 100% |  | 2013-10-01 | 2013-10-28 |  |  | 8/5 M-F w/JLAB Holidays ReBaseline | ELEC ENG [52.8 h]; ELEC DES [12 h]; ELEC TECH [78 h]; SUPPLIES & MATERIALS | 10,977.44 | 8,021.93 |  |  |  | 0 | GARZA O | 1 | 1 | S | MIKE S |  |  |  |  |  | 10-070 |  |  |  |  |  |  |  | 08-016 | 09-012 | 10-031 |  |  | 23612030 | 10721.928 | ST | PE | PE | PE | 13-015 | PR |  |  |
| 23612035 |  | Harp Systems Software Implementn & Cmmssng |  | 20d | 2013-09-03 A | 2013-09-28 A | 23612030 FS-20d | 100% |  | 2013-10-01 | 2013-10-28 |  |  | 8/5 M-F w/JLAB Holidays ReBaseline | COMP SCIENT [96 h]; ELEC ENG [16 h]; ELEC TECH [16 h] | 8,661.44 | 8,393.76 |  |  |  | 0 | GARZA O | 1 | 1 | H | MIKE S |  |  |  |  |  | 10-070 |  |  |  |  |  |  | 12-053 |  |  |  |  |  | 23612035 | 8393.76 |  |  | PE |  | 13-015 | PR |  |  |
| 23612913LOE |  | FY13 Mngmnt Effort for Harps |  | 20d | 2013-09-03 A | 2013-09-30 A | 9-130M FS+228d | 100% |  | 2013-10-01 | 2013-10-28 |  |  | 8/5 M-F w/JLAB Holidays ReBaseline | SCIENTIST [2.68 h] | 201.48 | 195.26 | 100 | 100 |  | 0 | GARZA O | 1 | 1 | E | MIKE S |  |  |  |  |  |  |  |  |  |  |  |  |  |  |  |  |  |  | 23612913LOE | 195.2648 |  |  | PE |  | 13-015 | PR |  |  |
| 23612035M |  | Harp Sys Comp | milestone | 0d | 2013-09-28 A | 2013-09-28 A | 23612035 | 100% |  | 2013-10-28 | 2013-10-28 |  |  | 8/5 M-F w/JLAB Holidays ReBaseline |  |  |  |  |  |  | 0 | GARZA O | 1 | 1 | M | MIKE S |  |  |  |  |  | 10-070 |  |  |  |  |  |  |  |  |  |  |  | 6 | 23612035M |  |  |  |  |  | 13-015 | PR |  |  |
|  | 3 | **1.3.6.1.3 VIEWERS** |  |  | 2009-01-02 | 2013-11-27 |  |  |  |  |  |  |  |  |  |  |  |  |  |  |  |  |  |  |  |  |  |  |  |  |  |  |  |  |  |  |  |  |  |  |  |  |  |  |  |  |  |  |  |  |  |  |  |  |
| 13613909LOE |  | FY09 Mngmnt Effort for Viewer Syss |  | 189d | 2009-01-02 A | 2009-09-30 A | 13613909LOEX | 100% |  |  |  |  |  |  | SR STAFF [24.39 h] | 2,508.27 | 2,508.27 | 100 | 100 | 0 | 2508.2676 | GARZA O | 1 | 1 | E | MIKE S | 08-058 |  |  |  |  |  |  |  |  |  |  |  |  |  |  |  |  |  |  |  |  |  |  |  |  |  |  |  |
| 13613910LOE |  | FY10 Mngmnt Effort for Viewer Syss |  | 248d | 2009-10-01 A | 2010-09-30 A | 13613909LOE | 100% |  |  |  |  |  |  | SR STAFF [32 h] | 3,395.84 | 3,395.84 | 100 | 100 | 0 | 3395.84 | GARZA O | 1 | 1 | E | MIKE S |  |  |  |  |  |  |  |  |  |  |  |  |  |  |  |  |  |  |  |  |  |  |  |  |  |  |  |  |
| 13613911LOE |  | FY11 Mngmnt Effort for Viewer Syss |  | 248d | 2010-10-01 A | 2011-09-30 A | 13613910LOE | 100% |  |  |  |  |  |  | SR STAFF [32 h] | 3,504.32 | 3,504.32 | 100 | 100 | 0 | 3504.32 | GARZA O | 1 | 1 | E | MIKE S |  | 8.46774193 | 91.53225806 |  |  |  |  |  |  |  |  |  |  |  |  |  |  |  |  |  |  |  |  |  |  |  |  |  |
| 13613912LOE |  | FY12 Mngmnt Effort for Viewer Syss |  | 247d | 2011-10-03 A | 2012-09-28 A | 13613911LOE | 100% |  |  |  |  |  |  | SR STAFF [32 h] | 3,616 | 3,616 | 100 | 100 | 0 | 3616 | GARZA O | 1 | 1 | E | MIKE S |  | 7.69230769 | 92.3076923 |  |  |  |  |  |  |  |  |  |  |  |  |  |  |  |  |  |  |  |  |  |  |  |  |  |
| 13613014 |  | Procurements for Viewer Syss |  | 74d | 2012-04-02 A | 2012-07-16 A | 121613040M, 9-120M FS+120d | 100% |  |  |  |  |  |  | SCIENTIST [100 h]; TRAVEL; SUPPLIES & MATERIALS; PROCUREMENT<$50K 60; ELEC ENG [80 h]; ELEC TECH [160 h] | 86,609.05 | 19,766.6 |  |  | 0 | 86609.05 | GARZA O | 1 | 1 | D | MIKE S |  |  |  |  |  | 10-070 | 0 | 62010.32 | 6201032 | 100 |  |  |  |  |  |  |  |  |  |  |  |  |  |  |  |  |  |  |
| 13613015 |  | Fab & Assy of Viewer Syss FY12 |  | 50d | 2012-06-05 A | 2012-08-13 A | 13613014 FS-20d, 9-120M | 100% |  |  |  |  |  |  | ELEC DES [19.33 h]; MECH TECH [19.33 h]; ELEC TECH [193.33 h]; SCIENTIST [38.67 h]; SUPPLIES & MATERIALS; TRAVEL; ELEC ENG [77.33 h] | 22,812.16 | 18,553.93 |  |  | 0 | 22812.1599 | GARZA O | 1 | 1 | U | MIKE S |  |  |  |  |  | 10-070 |  |  |  |  | Install | OPC A | 12-053 | 08-016 | 09-012 |  |  |  |  |  |  |  |  |  |  |  |  |  |
| 13613015a |  | Fab & Assy of Viewer Syss FY13 |  | 50d | 2012-06-05 A | 2012-08-13 A | 13613015 | 100% |  |  |  |  |  |  | SUPPLIES & MATERIALS; TRAVEL; SCIENTIST [41.33 h]; ELEC ENG [82.67 h]; ELEC DES [20.67 h]; MECH TECH [20.67 h]; ELEC TECH [206.67 h] | 24,531.6 | 19,834.47 |  |  | 0 | 25164.6349 | GARZA O | 1 | 1 | U | MIKE S |  |  |  |  |  | 10-070 |  |  |  |  |  |  | 12-053 | 08-016 | 09-012 |  |  |  |  |  |  |  |  |  |  |  |  |  |
| 13613015b |  | Fab & Assy of Viewer Syss Procurement |  | 50d | 2012-06-05 A | 2012-08-13 A | 9-120M, 13613014 FS-20d | 100% |  |  |  |  |  |  | PROCUREMENT<$50K 60 NO ESCALATION FY13 | 11,700.06 |  |  |  | 0 | 11700.06 | GARZA O | 1 | 1 | U | MIKE S |  |  |  |  |  | 10-070 | 0 | 11700.06 | 1170006 | 100 |  |  | 12-053 | 08-016 | 09-012 |  |  |  |  |  |  |  |  |  |  |  |  |  |
| 13613020 |  | Testing of Viewer Sys Compnts |  | 131d | 2012-08-20 A | 2013-04-15 A | 13613015, 13613015a, 13613015b | 100% |  | 2012-08-20 | 2013-03-05 |  |  |  | ELEC TECH [160 h]; SCIENTIST [20 h]; COMP SCIENT [320 h]; PROCUREMENT<$50K 60; ELEC ENG [40 h] | 39,131.99 | 33,136.62 |  |  | 0 | 39359.86 | GARZA O | 1 | 1 | U | MIKE S |  |  |  |  |  | 10-070 | 0 | 6036.66 | 603666 | 100 |  | OPC A |  |  |  |  |  |  |  |  |  |  |  |  |  |  |  |  |
| 13613913LOE |  | FY13 Mngmnt Effort for Viewer Syss |  | 248d | 2012-10-01 A | 2013-08-30 A | 13613912LOE | 100% |  | 2012-10-01 | 2013-09-30 |  |  |  | SR STAFF [29.42 h] | 3,430.37 | 3,430.37 | 100 | 100 | 632.06528 | 3430.370746 | GARZA O | 1 | 1 | E | MIKE S |  | 8.06458387 | 91.93541612 |  |  |  |  |  |  |  |  | OPC A |  |  |  |  |  |  |  |  |  |  |  |  |  |  |  |  |
| 13613025 |  | Implementn of Viewer Syss |  | 158d | 2012-10-08 A | 2013-08-30 A | 1362025, 13613020 FS-100d | 100% |  | 2012-10-08 | 2013-05-30 |  |  |  | ELEC ENG [2.86 h]; ELEC DES [2.86 h]; MECH TECH [2.86 h]; ELEC TECH [20 h]; PROCUREMENT<$50K 60 NO ESCALATION FY14 | 1,398.7 | 1,398.7 |  |  | 14620.72 | 1398.70149 | GARZA O | 1 | 1 | H | MIKE S |  |  |  |  |  | 10-070 |  |  |  |  |  | OPC A |  | 08-016 | 09-012 |  |  |  |  |  |  |  |  |  |  |  |  |  |
| 13613030 |  | Software Implementn Viewer Systems |  | 178d | 2012-11-12 A | 2013-08-30 A | 9-130M, 13613025 FS-150d, 121613040M | 100% |  | 2012-11-12 | 2013-08-02 |  |  |  | ELEC ENG [14.55 h]; ELEC TECH [29.09 h]; SCIENTIST [4.85 h]; COMP SCIENT [19.39 h] | 4,050.35 | 4,050.35 |  |  | 16707.4 | 4050.351101 | GARZA O | 1 | 1 | H | MIKE S |  |  |  |  |  | 10-070 |  |  |  |  |  | OPC A |  |  |  |  |  |  |  |  |  |  |  |  |  |  |  |  |
| 13613950 |  | Re-Baseline Actuals Adjustment |  | 1d | 2013-08-30 A | 2013-08-30 A |  | 100% |  | 2013-09-03 | 2013-09-03 |  |  |  | PROCUREMENT>$50K 69 NO ESCALATION | 163,320.24 |  |  |  |  | 163320.24 |  |  |  |  |  |  |  |  |  |  |  | 0 | 163320.24 | 16332024 | 100 |  |  |  |  |  |  | ADJ |  |  |  |  |  |  |  |  |  |  |  |
| 13613035M |  | Viewers Sys Comp | milestone | 0d | 2013-08-30 A | 2013-08-30 A | 1363030a, 1362035M, 13613030, 1363035, 13613020, 13613025 | 100% |  | 2013-11-04 | 2013-11-04 |  |  |  |  |  |  |  |  |  | 0 | GARZA O | 1 | 1 | M | MIKE S |  |  |  |  |  | 10-070 |  |  |  |  |  |  |  |  |  |  |  | 6 |  |  |  |  |  |  |  |  |  |  |
| 23613025a |  | Implementn of Viewer Syss Labor |  | 20d | 2013-09-03 A | 2013-11-27 | 23458065a FS-100d, 9-130M FS+228d, 23458065 FS-100d | 50% | 19d | 2013-10-01 | 2013-10-28 | 19d | 0d | 8/5 M-F w/JLAB Holidays ReBaseline | ELEC DES [10 h]; ELEC TECH [70 h] | 3,827.1 | 2,616.19 |  |  |  | 0 | GARZA O | 1 | 1 | H | MIKE S |  |  |  |  |  | 10-070 |  |  |  |  |  |  |  | 08-016 | 09-012 |  |  |  | 23613025a | 1854.5 |  |  | PE |  | 13-015 | PR |  |  |
| 23613030 |  | Software Implementn Viewer Systems |  | 20d | 2013-09-03 A | 2013-11-27 | 23613025a FS-20d | 30% | 19d | 2013-10-01 | 2013-10-28 | 19d | 0d | 8/5 M-F w/JLAB Holidays ReBaseline | COMP SCIENT [160 h]; ELEC TECH [120 h] | 16,818 | 11,496.48 |  |  |  | 4889.52 | GARZA O | 1 | 1 | S | MIKE S |  |  |  |  |  | 10-070 |  |  |  |  |  |  |  |  |  |  |  |  | 23613030 |  | ST |  | PE |  | 13-015 | PR |  |  |
| 23613913LOE |  | FY13 Mngmnt Effort for Viewer Syss |  | 20d | 2013-09-03 A | 2013-09-30 A | 9-130M FS+228d | 100% |  | 2013-10-01 | 2013-10-28 |  |  | 8/5 M-F w/JLAB Holidays ReBaseline | SCIENTIST [2.68 h] | 201.48 | 195.26 | 100 | 100 |  | 0 | GARZA O | 1 | 1 | E | MIKE S |  |  |  |  |  |  |  |  |  |  |  |  |  |  |  |  |  |  | 23613913LOE | 195.2648 |  |  | PE |  | 13-015 | PR |  |  |
| 23613050 |  | SLM System Controls |  | 43d | 2013-09-16 A | 2013-10-21 A | 9-140M | 100% |  | 2013-10-01 | 2013-12-02 |  |  | 8/5 M-F w/JLAB Holidays ReBaseline | ELEC TECH [28 h]; PROCUREMENT<$50K 60 | 10,086.87 | 1,309.92 |  |  |  | 5043.435 | GARZA O | 1 | 1 | H | MIKE S |  |  |  |  |  | 10-070 | 0 | 8771.15 | 877115 | 100 |  |  |  |  |  |  |  |  | 23613050 | 5043.435 |  | PE | PE |  | 13-015 | PR | OB-2 | 14-001 |
| 23613035M |  | Viewers Sys Comp | milestone | 0d | 2013-11-27 | 2013-11-27 | 23613030, 23613025a |  |  |  |  | 19d | 0d | 8/5 M-F w/JLAB Holidays ReBaseline |  |  |  |  |  |  | 0 | GARZA O | 1 | 1 | M | MIKE S |  |  |  |  |  | 10-070 |  |  |  |  |  |  |  |  |  |  |  | 6 | 23613035M |  |  |  |  |  | 13-015 | PR |  |  |

Notes:
- 13612025: Entry Criteria: Ext Pred: Girders, beamline, / IOCs and network installed
- 23612030: Entry Criteria: Ext Pred: Girders, beamline, / IOCs and network installed / Steps: Harp Sys Implementn Labor (done)
- 13613025: Entry Criteria: Ext Pred: Girders, beamline, / IOCs and network installed
- 13613030: Entry Criteria: Ext Pred: Beam
- 23613025a: Entry Criteria: Ext Pred: Girders, beamline, / IOCs and network installed
- 23613030: Entry Criteria: Ext Pred: Beam / Steps: Standard Viewer (done); SLM Viewer
- 23613050: Entry Criteria: Ext Pred: Beam

| ID | WBS | Activity | Type | Duration | Start | Finish | Predecessors | Complete | Planned start | Planned finish | Total float | Free float | Calendar | Resources | Cost | Actual cost | LOE Divider | LOE Multiplier | Calculated Remaining Total Cost | MONTHLY EV COST | RESP - Responsibility | STRT%COMP for CM EVM | FNSH%COMP for CM EVM | EVMS Reporting Codes | CAM RESPONSIBLE | CR 08-058 | LOE % Pre Calc | LOE % | Remaining Material Cost Based on % Compl | Claimed Material Cost Based on % Complet | Initial Claimed Material Calc | Claimed Material Divider | CR 10-070 | CR 11-026 | OPC Allison | Installation | ReBaseline Actuals Adjustment | Original Activity ID Rebaseline | BOE Procurement | BOE Labor | BOE Expenses | CR 13-015 | Post Rebaseline | CR 14-001 | CR 10-031 | CR 12-005 | CR 12-026 | CR 12-025 | Milestone Level | CR 12-018 | CR 12-037 | CR 11-001 | CR 08-016 | CR 09-012 | CR 13-003 | CR 12-053 | MARCH!!! |
| --- | --- | --- | --- | --- | --- | --- | --- | --- | --- | --- | --- | --- | --- | --- | --- | --- | --- | --- | --- | --- | --- | --- | --- | --- | --- | --- | --- | --- | --- | --- | --- | --- | --- | --- | --- | --- | --- | --- | --- | --- | --- | --- | --- | --- | --- | --- | --- | --- | --- | --- | --- | --- | --- | --- | --- | --- | --- |
|  | 4 | **1.3.6.1.4 BEAM-BASED FEEDBACK SYSTEMS** |  |  | 2009-01-02 | 2014-09-19 |  |  |  |  |  |  |  |  |  |  |  |  |  |  |  |  |  |  |  |  |  |  |  |  |  |  |  |  |  |  |  |  |  |  |  |  |  |  |  |  |  |  |  |  |  |  |  |  |  |  |  |
| 13614909LOE |  | FY09 FFB Sys Mangement Effort |  | 189d | 2009-01-02 A | 2009-09-30 A | 13614909LOEX | 100% |  |  |  |  |  | SR STAFF [3.05 h] | 313.66 | 313.66 | 100 | 100 | 0 | 313.66117 | GARZA O | 1 | 1 | E | MIKE S | 08-058 |  |  |  |  |  |  |  |  |  |  |  |  |  |  |  |  |  |  |  |  |  |  |  |  |  |  |  |  |  |  |  |
| 13614910LOE |  | FY10 FFB Sys Mangement Effort |  | 248d | 2009-10-01 A | 2010-09-30 A | 13614909LOE | 100% |  |  |  |  |  | SR STAFF [4 h] | 424.48 | 424.48 | 100 | 100 | 0 | 424.48 | GARZA O | 1 | 1 | E | MIKE S |  |  |  |  |  |  |  |  |  |  |  |  |  |  |  |  |  |  |  |  |  |  |  |  |  |  |  |  |  |  |  |  |
| 13614911LOE |  | FY11 FFB Sys Mangement Effort |  | 248d | 2010-10-01 A | 2011-09-30 A | 13614910LOE | 100% |  |  |  |  |  | SR STAFF [112 h] | 12,265.12 | 12,265.12 | 100 | 100 | 0 | 12265.12 | GARZA O | 1 | 1 | E | MIKE S |  | 8.46774193 | 91.53225806 |  |  |  |  |  |  |  |  |  |  |  |  |  |  |  |  |  |  |  |  |  |  |  |  |  |  |  |  |  |
| 13614014 |  | FFB Sys Prcrmnts |  | 55d | 2013-08-30 A | 2013-08-30 A | 9-130M FS+130d, 2-02M FS+180d, 121614035M, 9-140M | 100% | 2013-10-01 | 2013-12-18 |  |  |  | ELEC TECH [60 h]; PROCUREMENT<$50K 60; SUPPLIES & MATERIALS | 101,095.99 | 2,732.4 |  |  | 101008.99 | 101008.99 | GARZA O | 1 | 1 | D | MIKE S |  |  |  | 0 | 94171.67 | 9417167 | 100 | 10-070 | 11-026 | OPC A |  |  |  |  |  |  |  |  |  |  |  |  |  |  |  |  |  |  |  |  |  |  |
| 13614015 |  | FFB Sys Fabriation & Assy |  | 43d | 2013-08-30 A | 2013-08-30 A | 13614014 FS-20d | 100% | 2013-11-19 | 2014-01-29 |  |  |  | PROCUREMENT<$50K 60; ELEC TECH [120 h]; SUPPLIES & MATERIALS; ELEC DES [40 h] | 13,983.6 | 7,549.6 |  |  | 13743.2 | 13743.2 | GARZA O | 1 | 1 | H | MIKE S |  |  |  | 0 | 1207.33 | 120733 | 100 | 10-070 | 11-026 | OPC A | Install |  |  |  |  |  |  |  |  |  |  |  |  |  |  |  |  |  |  |  |  |  |
| 13614020 |  | FFB Sys Component & VME Testing |  | 43d | 2013-08-30 A | 2013-08-30 A | 13614014 FS-20d | 100% | 2013-11-19 | 2014-01-29 |  |  |  | PROCUREMENT<$50K 60; ELEC ENG [60 h]; ELEC TECH [80 h]; COMP SCIENT [60 h] | 16,201.91 | 12,074.4 |  |  | 15817.11 | 15817.11 | GARZA O | 1 | 1 | H | MIKE S |  |  |  | 0 | 3742.71 | 374271 | 100 | 10-070 | 11-026 | OPC A |  |  |  |  |  |  |  |  |  |  |  |  |  |  |  |  |  |  |  |  |  |  |
| 13614950 |  | Re-Baseline Actuals Adjustment |  | 1d | 2013-08-30 A | 2013-08-30 A |  | 100% | 2013-09-03 | 2013-09-03 |  |  |  | PROCUREMENT>$50K 69 NO ESCALATION | -141,294.4 |  |  |  |  |  |  |  |  |  |  |  |  |  |  |  |  | 100 |  |  |  |  | ADJ |  |  |  |  |  |  |  |  |  |  |  |  |  |  |  |  |  |  |  |  |
| 23614014 |  | FFB Sys Prcrmnts |  | 55d | 2014-03-04 | 2014-05-19 | 9-140M FS+100d |  |  |  | 50d | 0d | 8/5 M-F w/JLAB Holidays ReBaseline | ELEC TECH [51 h]; SUPPLIES & MATERIALS; PROCUREMENT<$50K 60 | 56,211.8 |  |  |  |  | 0 | GARZA O | 1 | 1 |  | MIKE S |  |  |  | 50214.83 | 0 | 0 | 100 | 10-070 | 11-026 |  |  |  | 23614014 | EV | PE | PE | 13-015 | PR | 14-001 |  |  |  |  |  |  |  |  |  |  |  |  |  |
| 23614050LOE |  | FY14 Mngmnt Effort for FFB |  | 140d | 2014-03-04 | 2014-09-18 | 9-140M FS+100d |  |  |  | 51d | 1d | 8/5 M-F w/JLAB Holidays ReBaseline | SCIENTIST [17 h] | 1,278.06 |  | 100 | 100 |  | 0 | GARZA O | 1 | 1 | E | MIKE S |  | 100 | 0 |  |  |  |  |  |  |  |  |  | 23614050LOE |  | PE |  |  | PR | 14-001 |  |  |  |  |  |  |  |  |  |  |  |  |  |
| 23614015 |  | FFB Sys Fabriation & Assy |  | 43d | 2014-04-22 | 2014-06-20 | 23614014 FS-20d |  |  |  | 50d | 0d | 8/5 M-F w/JLAB Holidays ReBaseline | ELEC ENG [136 h]; PROCUREMENT<$50K 60; ELEC TECH [204 h]; ELEC DES [34 h]; SUPPLIES & MATERIALS | 27,064.66 |  |  |  |  | 0 | GARZA O | 1 | 1 |  | MIKE S |  |  |  | 1058.97 | 0 | 0 | 100 | 10-070 | 11-026 |  |  |  | 23614015 | PE | PE | PE | 13-015 | PR | 14-001 |  |  |  |  |  |  |  |  |  |  |  |  |  |
| 23614020 |  | FFB Sys Component & VME Testing |  | 43d | 2014-04-22 | 2014-06-20 | 23614014 FS-20d |  |  |  | 113d | 63d | 8/5 M-F w/JLAB Holidays ReBaseline | ELEC TECH [68 h]; ELEC ENG [68 h]; PROCUREMENT<$50K 60 | 11,586.94 |  |  |  |  | 0 | GARZA O | 1 | 1 |  | MIKE S |  |  |  | 3282.78 | 0 | 0 | 100 | 10-070 | 11-026 |  |  |  | 23614020 | PE | PE |  | 13-015 | PR | 14-001 |  |  |  |  |  |  |  |  |  |  |  |  |  |
| 23614030 |  | FFB Software Implementn |  | 48d | 2014-05-23 | 2014-07-31 | 23614025 FS-40d |  |  |  | 50d | 0d | 8/5 M-F w/JLAB Holidays ReBaseline | ELEC ENG [68 h]; COMP SCIENT [149.6 h]; ELEC TECH [68 h] | 18,756.71 |  |  |  |  | 0 | GARZA O | 1 | 1 |  | MIKE S |  |  |  |  |  |  |  | 10-070 | 11-026 |  |  |  | 23614030 |  | PE |  | 13-015 | PR | 14-001 | 10-031 | 12-005 | 12-026 |  |  |  |  |  |  |  |  |  |  |
| 23614025 |  | FFB Sys Hardware Implementn |  | 20d | 2014-06-23 | 2014-07-21 | 23611035M, 23614015 |  |  |  | 50d | 0d | 8/5 M-F w/JLAB Holidays ReBaseline | SUPPLIES & MATERIALS; ELEC TECH [68 h] | 7,322.92 |  |  |  |  | 0 | GARZA O | 1 | 1 |  | MIKE S |  |  |  |  |  |  |  | 10-070 | 11-026 |  |  |  | 23614025 |  | PE | PE | 13-015 | PR | 14-001 |  | 12-005 | 12-026 |  |  |  |  |  |  |  |  |  |  |
| 23614035 |  | FFB Slow Lock Implementn |  | 30d | 2014-08-01 | 2014-09-12 | 23614030 |  |  |  | 50d | 0d | 8/5 M-F w/JLAB Holidays ReBaseline | COMP SCIENT [68 h] | 4,751.16 |  |  |  |  | 0 | GARZA O | 1 | 1 |  | MIKE S |  |  |  |  |  |  |  | 10-070 | 11-026 |  |  |  | 23614035 |  | PE |  | 13-015 | PR | 14-001 | 10-031 | 12-005 | 12-026 |  |  |  |  |  |  |  |  |  |  |
| 23614040 |  | FFB Slow Lock & FFB Cmmssng |  | 15d | 2014-08-29 | 2014-09-19 | 23611035M, 32-05M, 23614035 FS-10d |  |  |  | 50d | 0d | 8/5 M-F w/JLAB Holidays ReBaseline | COMP SCIENT [68 h]; ELEC TECH [17 h]; ELEC ENG [17 h] | 6,827.2 |  |  |  |  | 0 | GARZA O | 1 | 1 |  | MIKE S |  |  |  |  |  |  |  | 10-070 | 11-026 |  |  |  | 23614040 |  | PE |  | 13-015 | PR | 14-001 |  | 12-005 | 12-026 | 12-025 |  |  |  |  |  |  |  |  |  |
| 23614045M |  | FFB Sys Comp | milestone | 0d | 2014-09-19 | 2014-09-19 | 23614025, 23614020, 23614050LOE, 23614040 |  |  |  | 50d | 42d | 8/5 M-F w/JLAB Holidays ReBaseline |  |  |  |  |  |  | 0 | GARZA O | 1 | 1 | M | MIKE S |  |  |  |  |  |  |  | 10-070 | 11-026 |  |  |  | 23614045M |  |  |  | 13-015 | PR |  |  | 12-005 | 12-026 | 12-025 | 6 |  |  |  |  |  |  |  |  |
|  | 2 | **1.3.6.2 CONTROL SYSTEM HARDWARE** |  |  | 2009-01-02 | 2013-08-30 |  |  |  |  |  |  |  |  |  |  |  |  |  |  |  |  |  |  |  |  |  |  |  |  |  |  |  |  |  |  |  |  |  |  |  |  |  |  |  |  |  |  |  |  |  |  |  |  |  |  |  |
| 1362909LOE |  | FY09 CSH Sys Mngmnt Effort |  | 189d | 2009-01-02 A | 2009-09-30 A | 1362909LOEX | 100% |  |  |  |  |  | SR STAFF [3.05 h] | 313.66 | 313.66 | 100 | 100 | 0 | 313.66117 | GARZA O | 1 | 1 | E | MIKE S | 08-058 |  |  |  |  |  |  |  |  |  |  |  |  |  |  |  |  |  |  |  |  |  |  |  |  |  |  |  |  |  |  |  |
| 1362910LOE |  | FY10 CSH Sys Mngmnt Effort |  | 248d | 2009-10-01 A | 2010-09-30 A | 1362909LOE | 100% |  |  |  |  |  | SR STAFF [4 h] | 424.48 | 424.48 | 100 | 100 | 0 | 424.48 | GARZA O | 1 | 1 | E | MIKE S |  |  |  |  |  |  |  |  |  |  |  |  |  |  |  |  |  |  |  |  |  |  |  |  |  |  |  |  |  |  |  |  |
| 1362014 |  | CSH Proc Compnts (multiple reqs) Linacs - Labor |  | 81d | 2010-04-01 A | 2010-07-26 A | 12162040M, 9-100M FS+120d | 100% |  |  |  |  |  | ELEC ENG [20 h]; ELEC TECH [40 h] | 2,983.4 | 2,983.4 |  |  | 0 | 2983.4 | GARZA O | 1 | 1 | H | MIKE S |  |  |  |  |  |  |  |  |  |  |  |  |  |  |  |  |  |  |  | 10-031 |  |  |  |  | 12-018F | 12-037F |  |  |  |  |  |  |
| 1362014A |  | CSH Proc Compnts (multiple reqs) Linacs - Procurements |  | 81d | 2010-04-01 A | 2010-07-26 A | 9-100M FS+120d | 100% |  |  |  |  |  | PROCUREMENT<$50K 60; PROCUREMENT>$50K 69 | 119,218.21 |  |  |  | 0 | 119218.21 | GARZA O | 1 | 1 | D | MIKE S |  |  |  | 0 | 119218.21 | 11921821 | 100 |  |  |  |  |  |  |  |  |  |  |  |  | 10-031 |  |  |  |  | 12-018F | 12-037F |  |  |  |  |  |  |
| 1362910ALOE |  | FY10 Engineering Oversight |  | 128d | 2010-04-01 A | 2010-09-30 A | 9-100M FS+120d | 100% |  |  |  |  |  | ELEC ENG [150.8 h] | 9,993.52 | 9,993.52 | 100 | 100 | 0 | 9993.516 | GARZA O | 1 | 1 | E | MIKE S |  |  |  |  |  |  |  |  |  |  |  |  |  |  |  |  |  |  |  | 10-031 |  |  |  |  |  |  |  |  |  |  |  |  |
| 1362015 |  | CSH Hardware Setup/Configuration Linacs - Labor FY10 |  | 72d | 2010-06-21 A | 2010-09-30 A | 1362014, 1362014A | 100% |  |  |  |  |  | ELEC TECH [150.86 h]; TRAVEL; ELEC ENG [50.29 h] | 12,079.17 | 9,585.87 |  |  | 0 | 12079.1653 | GARZA O | 1 | 1 | H | MIKE S |  |  |  |  |  |  |  |  |  |  |  |  |  |  |  |  |  |  |  | 10-031 |  |  |  |  | 12-018F | 12-037F | 11-001 |  |  |  |  |  |
| 1362015ab |  | CSH Hardware Setup/Configuration Linacs - Labor FY11 |  | 72d | 2010-06-21 A | 2010-09-30 A | 1362015 | 100% |  |  |  |  |  | ELEC TECH [89.14 h]; TRAVEL; ELEC ENG [29.71 h] | 7,184.05 | 5,663.73 |  |  | 0 | 7364.4076 | GARZA O | 1 | 1 | H | MIKE S |  |  |  |  |  |  |  |  |  |  |  |  |  |  |  |  |  |  |  | 10-031 |  |  |  |  | 12-018F | 12-037F | 11-001 |  |  |  |  |  |
| 1362015A |  | CSH Hardware Setup/Configuration Linacs - Procurement |  | 64d | 2010-07-01 A | 2010-09-30 A | 1362014, 1362014A | 100% |  |  |  |  |  | PROCUREMENT<$50K 60 NO ESCALATION FY11 | 7,691.5 |  |  |  | 0 | 7691.5 | GARZA O | 1 | 1 | D | MIKE S |  |  |  | 0 | 7691.5 | 769150 | 100 |  |  |  |  |  |  |  |  |  |  |  |  | 10-031 |  |  |  |  | 12-018F | 12-037F |  |  |  |  |  |  |
| 1362911LOE |  | FY11 CSH Sys Mngmnt Effort (Including Engineering Oversight) |  | 248d | 2010-10-01 A | 2011-09-30 A | 1362910LOE, 1362910ALOE | 100% |  |  |  |  |  | SR STAFF [60 h]; ELEC ENG [150.8 h] | 16,882.3 | 16,882.3 | 100 | 100 | 0 | 16882.304 | GARZA O | 1 | 1 | E | MIKE S |  | 8.46774193 | 91.53225806 |  |  |  |  |  |  |  |  |  |  |  |  |  |  |  |  | 10-031 |  |  |  |  |  |  |  |  |  |  |  |  |
| 1362020 |  | CSH Installtn Network/Controls Linacs - Labor |  | 57d | 2010-11-15 A | 2011-02-14 A | 1362015ab, 1362015A | 100% |  |  |  |  |  | PLABOR; ELEC DES [40 h]; ELEC TECH [120 h] | 8,990.72 | 7,090.4 |  |  | 0 | 8990.72 | GARZA O | 1 | 1 | H | MIKE S |  |  |  |  |  |  |  |  |  |  |  |  |  |  |  |  |  |  |  | 10-031 |  |  |  |  | 12-018F | 12-037F |  | 08-016 | 09-012 |  |  |  |
| 1362020A |  | CSH Installtn Network/Controls Linacs - Procurement |  | 44d | 2010-12-06 A | 2011-02-14 A | 1362015ab, 1362015A | 100% |  |  |  |  |  | PROCUREMENT<$50K 60 | 10,204.53 |  |  |  | 0 | 10204.53 | GARZA O | 1 | 1 | D | MIKE S |  |  |  | 0 | 10204.53 | 1020453 | 100 |  |  |  |  |  |  |  |  |  |  |  |  | 10-031 |  |  |  |  | 12-018F |  |  |  |  |  |  |  |
| 1362025 |  | CSH Commisioning Network/Controls Linacs |  | 73d | 2011-02-15 A | 2011-05-29 A | 1362020A FS-30d, 1362020 | 100% | 2011-02-15 | 2011-05-27 |  |  |  | COMP SCIENT [80 h]; ELEC ENG [40 h]; ELEC TECH [140 h] | 13,810.2 | 13,810.2 |  |  | 0 | 13810.2 | GARZA O | 1 | 1 | H | MIKE S |  |  |  |  |  |  |  |  |  |  |  |  |  |  |  |  |  |  |  | 10-031 |  |  |  |  | 12-018F |  |  |  |  |  |  |  |
| 1362912LOE |  | FY12 CSH Sys Mngmnt Effort (Including Engineering Oversight) |  | 247d | 2011-10-03 A | 2012-09-28 A | 1362911LOE | 100% |  |  |  |  |  | SR STAFF [60 h]; ELEC ENG [150.8 h] | 17,420.45 | 17,420.45 | 100 | 100 | 0 | 17420.448 | GARZA O | 1 | 1 | E | MIKE S |  | 7.69230769 | 92.3076923 |  |  |  |  |  |  |  |  |  |  |  |  |  |  |  |  | 10-031 |  |  |  |  |  |  |  |  |  |  |  |  |
| 1362014B |  | CSH Proc Compnts (multiple reqs) Tagger Service Building - Labor |  | 121d | 2011-10-10 A | 2012-04-09 A | 9-120M | 100% |  |  |  |  |  | ELEC TECH [40 h]; ELEC ENG [20 h] | 3,176.4 | 3,176.4 |  |  | 0 | 3176.4 | GARZA O | 1 | 1 | H | MIKE S |  |  |  |  |  |  |  | 10-070 |  |  |  |  |  |  |  |  |  |  |  | 10-031 |  |  |  |  |  |  |  |  |  |  |  |  |
| 1362014C |  | CSH Proc Compnts (multiple reqs) Tagger Service Building - Procurements |  | 48d | 2012-02-01 A | 2012-04-09 A | 9-120M FS+90d | 100% |  |  |  |  |  | PROCUREMENT<$50K 60; PROCUREMENT>$50K 69 | 126,945.64 |  |  |  | 0 | 126945.64 | GARZA O | 1 | 1 | D | MIKE S |  |  |  | 0 | 126945.64 | 12694564 | 100 | 10-070 |  |  |  |  |  |  |  |  |  |  |  | 10-031 |  |  |  |  |  |  |  |  |  |  |  |  |
| 1362015B |  | CSH Hardware Setup/Configuration Tagger Service Building - Labor |  | 84d | 2012-03-12 A | 2012-07-09 A | 1362014B FS-20d, 1362014C FS-20d | 100% |  |  |  |  |  | ELEC ENG [80 h]; ELEC TECH [240 h]; TRAVEL | 20,459.71 | 16,236 |  |  | 0 | 20459.71 | GARZA O | 1 | 1 | H | MIKE S |  |  |  |  |  |  |  | 10-070 |  | OPC A |  |  |  |  |  |  |  |  |  | 10-031 |  |  |  |  |  |  |  |  |  |  |  |  |
| 1362020B |  | CSH Installtn Network/Controls Tagger Service Building - Labor |  | 109d | 2012-03-12 A | 2012-08-13 A | 1362015C FS-150d, 1362015B FS-150d | 100% |  |  |  |  |  | ELEC TECH [120 h]; PLABOR; ELEC DES [40 h] | 9,276.93 | 7,316 |  |  | 0 | 9276.93 | GARZA O | 1 | 1 | H | MIKE S |  |  |  |  |  |  |  | 10-070 |  |  |  |  |  |  |  |  |  |  |  | 10-031 |  |  |  |  |  |  |  |  |  |  |  |  |
| 1362015C |  | CSH Hardware Setup/Configuration Tagger Service Building - Procurement |  | 49d | 2012-04-02 A | 2012-06-11 A | 1362014B, 1362014C | 100% |  |  |  |  |  | PROCUREMENT<$50K 60 | 8,190.05 |  |  |  | 0 | 8190.05 | GARZA O | 1 | 1 | D | MIKE S |  |  |  | 0 | 8190.05 | 819005 | 100 | 10-070 |  | OPC A |  |  |  |  |  |  |  |  |  | 10-031 |  |  |  |  |  |  |  |  |  |  |  |  |
| 1362020C |  | CSH Installtn Network/Controls Tagger Service Building - Procurement |  | 26d | 2012-04-09 A | 2012-05-14 A | 1362015B FS-135d, 1362015C FS-135d | 100% |  |  |  |  |  | PROCUREMENT<$50K 60 | 10,530.05 |  |  |  | 0 | 10530.05 | GARZA O | 1 | 1 | D | MIKE S |  |  |  | 0 | 10530.05 | 1053005 | 100 | 10-070 |  | OPC A |  |  |  |  |  |  |  |  |  | 10-031 |  |  |  |  |  |  |  |  |  |  |  |  |
| 1362030 |  | CSH Gateway , Data Storage, CPU Capacity |  | 123d | 2012-10-01 A | 2013-03-11 A | 1362025, 1362025Aa FS-120d | 100% | 2012-10-01 | 2013-04-03 |  |  |  | PROCUREMENT<$50K 60; COMP SCIENT [160 h]; TRAVEL | 87,658.4 | 10,833.6 |  |  | 0 | 87658.4 | GARZA O | 1 | 1 | D | MIKE S |  |  |  | 0 | 72707.81 | 7270781 | 100 | 10-070 |  | OPC A |  |  |  |  |  |  |  |  |  | 10-031 |  |  |  |  |  |  |  | 08-016 | 09-012 | 13-003 |  |  |
| 1362025A |  | CSH Commisioning Network/Controls Tagger Service Building FY12 |  | 27d | 2013-01-14 A | 2013-02-11 A | 1362020C, 1362020B, 9-130M FS+60d | 100% | 2013-02-01 | 2013-03-12 |  |  |  | ELEC ENG [15.43 h]; ELEC TECH [54 h]; COMP SCIENT [30.86 h] | 5,672.15 | 5,672.15 |  |  | 0 | 5496.794 | GARZA O | 1 | 1 | H | MIKE S |  |  |  |  |  |  |  | 10-070 |  | OPC A |  |  |  |  |  |  |  |  |  | 10-031 |  |  |  |  |  |  |  |  |  |  | 12-053 | XX |
| 1362027 |  | East Arc 12Gev Network Upgrade Installations |  | 100d | 2013-01-14 A | 2013-03-11 A | 1362025 FS-40d, 1362025Aa FS-50d | 100% | 2013-05-13 | 2013-10-02 |  |  |  | PROCUREMENT<$50K 60; ELEC TECH [200 h]; ELEC ENG [16 h] | 12,279.5 | 10,272.96 |  |  | 0 | 12272.96 | GARZA O | 1 | 1 | H | MIKE S |  |  |  | 0 | 2000 | 200000 | 100 | 10-070 |  |  |  |  |  |  |  |  |  |  |  | 10-031 |  |  |  |  |  |  |  | 08-016 | 09-012 | 13-003 |  |  |
| 1362026 |  | East Arc 12Gev Network Upgrade Procuremnts |  | 100d | 2013-01-21 A | 2013-03-11 A | 1362025, 1362025Aa FS-70d | 100% | 2013-05-13 | 2013-10-02 |  |  |  | PROCUREMENT<$50K 60; ELEC ENG [16 h]; ELEC TECH [40 h] | 14,988.46 | 2,986.56 |  |  | 0 | 14986.56 | GARZA O | 1 | 1 | D | MIKE S |  |  |  | 0 | 12000 | 1200000 | 100 | 10-070 |  |  |  |  |  |  |  |  |  |  |  | 10-031 |  |  |  |  |  |  |  | 08-016 | 09-012 | 13-003 |  |  |
| 1362028 |  | East Arc 12Gev Network Upgrade Testing |  | 100d | 2013-01-21 A | 2013-04-15 A | 1362025Aa FS-50d, 1362025 FS-40d | 100% | 2013-05-13 | 2013-10-02 |  |  |  | ELEC TECH [80 h] | 3,645.52 | 3,643.2 |  |  | 0 | 3643.2 | GARZA O | 1 | 1 | H | MIKE S |  |  |  |  |  |  |  | 10-070 |  |  |  |  |  |  |  |  |  |  |  | 10-031 |  |  |  |  |  |  |  | 08-016 | 09-012 | 13-003 |  |  |
| 1362025Aa |  | CSH Commisioning Network/Controls Tagger Service Building FY13 |  | 43d | 2013-02-04 A | 2013-03-11 A | 1362025A | 100% | 2013-04-09 | 2013-06-07 |  |  |  | ELEC ENG [24.57 h]; ELEC TECH [86 h]; COMP SCIENT [49.14 h] | 9,032.65 | 9,032.65 |  |  | 0 | 9032.6511 | GARZA O | 1 | 1 | H | MIKE S |  |  |  |  |  |  |  | 10-070 |  |  |  |  |  |  |  |  |  |  |  | 10-031 |  |  |  |  |  |  |  |  |  |  | 12-053 |  |
| 1362035M |  | CSH Comp Milestone | milestone | 0d | 2013-08-26 A | 2013-08-26 A | 1362025, 1362027, 1362030, 1362026, 1362028 | 100% | 2013-09-03 | 2013-09-03 |  |  |  |  |  |  |  |  |  | 0 | GARZA O | 1 | 1 | M | MIKE S |  |  |  |  |  |  |  | 10-070 |  | OPC A |  |  |  |  |  |  |  |  |  | 10-031 |  |  |  | 6 |  |  |  |  |  |  |  |  |
| 1362950 |  | Re-Baseline Actuals Adjustment |  | 1d | 2013-08-30 A | 2013-08-30 A |  | 100% | 2013-09-03 | 2013-09-03 |  |  |  | PROCUREMENT>$50K 69 NO ESCALATION | -74,543.5 |  |  |  |  |  |  |  |  |  |  |  |  |  |  |  |  | 100 |  |  |  |  | ADJ |  |  |  |  |  |  |  |  |  |  |  |  |  |  |  |  |  |  |  |  |

Notes:
- 23614025: Entry Criteria: Ext Pred: Correctors, BPMs, RF, / IOCs, network installed
- 23614040: Entry Criteria: Required predecessor: Beam / Ext Pred: Correctors, BPMs, RF, IOCs, network beam / sync functioning
- 1362020: Entry Criteria: Ext Pred: BOD new service / building
- 1362020A: Entry Criteria: Ext Pred: BOD new service / building
- 1362020B: Entry Criteria: Ext Pred: BOD new service / building
- 1362020C: Entry Criteria: Ext Pred: BOD new service / building

| ID | WBS | Activity | Duration | Start | Finish | Predecessors | Complete | Planned start | Planned finish | Calendar | Resources | Cost | Actual cost | LOE Divider | LOE Multiplier | Calculated Remaining Total Cost | MONTHLY EV COST | RESP - Responsibility | STRT%COMP for CM EVM | FNSH%COMP for CM EVM | EVMS Reporting Codes | CAM RESPONSIBLE | CR 08-058 | LOE % Pre Calc | LOE % | CR 08-016 | CR 08-052 | CR 09-012 | CR 10-070 | CR 11-038 | CR 12-029 | Remaining Material Cost Based on % Compl | Claimed Material Cost Based on % Complet | Initial Claimed Material Calc | Claimed Material Divider | OPC Allison | Activities with Steps | CR 12-053 | CR 11-026 | CR 12-018 | CR 12-035 | MARCH!!! | CR 10-031 | CR 10-064 | ReBaseline Actuals Adjustment | Original Activity ID Rebaseline | BOE Labor | BOE Adder | CR 13-015 | Post Rebaseline | PRIOR MONTH EV COST |
| --- | --- | --- | --- | --- | --- | --- | --- | --- | --- | --- | --- | --- | --- | --- | --- | --- | --- | --- | --- | --- | --- | --- | --- | --- | --- | --- | --- | --- | --- | --- | --- | --- | --- | --- | --- | --- | --- | --- | --- | --- | --- | --- | --- | --- | --- | --- | --- | --- | --- | --- | --- |
|  | 3 | **1.3.6.3 CONTROL SYSTEM SOFTWARE** |  | 2009-01-02 | 2013-10-21 |  |  |  |  |  |  |  |  |  |  |  |  |  |  |  |  |  |  |  |  |  |  |  |  |  |  |  |  |  |  |  |  |  |  |  |  |  |  |  |  |  |  |  |  |  |  |
| 1363909LOE |  | FY09 CSS Sys Mngmnt Effort | 189d | 2009-01-02 A | 2009-09-30 A | 1363909LOEX | 100% |  |  |  | SR STAFF [18.29 h] | 1,880.94 | 1,880.94 | 100 | 100 | 0 | 1880.9436 | BICKLEY M | 1 | 1 | E | MIKE S | 08-058 |  |  |  |  |  |  |  |  |  |  |  |  |  |  |  |  |  |  |  |  |  |  |  |  |  |  |  |  |
| 1363910LOE |  | FY10 CSS Sys Mngmnt Effort | 248d | 2009-10-01 A | 2010-09-30 A | 1363909LOE | 100% |  |  |  | SR STAFF [24 h] | 2,546.88 | 2,546.88 | 100 | 100 | 0 | 2546.878716 | BICKLEY M | 1 | 1 | E | MIKE S |  |  |  |  |  |  |  |  |  |  |  |  |  |  |  |  |  |  |  |  |  |  |  |  |  |  |  |  |  |
| 1363911LOE |  | FY11 CSS Sys Mngmnt Effort | 248d | 2010-10-01 A | 2011-09-30 A | 1363910LOE | 100% |  |  |  | SR STAFF [24 h] | 2,628.24 | 2,628.24 | 100 | 100 | 0 | 2628.238675 | BICKLEY M | 1 | 1 | E | MIKE S |  | 8.46774193 | 91.53225806 |  |  |  |  |  |  |  |  |  |  |  |  |  |  |  |  |  |  |  |  |  |  |  |  |  |  |
| 1363015 |  | Update Hi-Level Applications Labor FY11 | 107d | 2011-05-02 A | 2011-09-30 A | 9-110M FS+140d | 100% |  |  |  | COMP SCIENT [527.5 h] | 33,543.73 | 33,543.73 |  |  | 0 | 33543.725 | BICKLEY M | 1 | 1 | H | MIKE S |  |  |  | 08-016 | 08-052 | 09-012 | 10-070 | 11-038 | 12-029F |  |  |  |  |  |  |  |  |  |  |  |  |  |  |  |  |  |  |  |  |
| 1363015b |  | Update Hi-Level Applications Procurement | 474d | 2011-05-02 A | 2013-04-15 A | 9-110M FS+140d | 100% | 2011-05-02 | 2013-03-29 |  | PROCUREMENT<$50K 60 NO ESCALATION FY12 | 5,850.59 |  |  |  | 0 | 5850.59 | BICKLEY M | 1 | 1 | D | MIKE S |  |  |  | 08-016 | 08-052 | 09-012 | 10-070 | 11-038 | 12-029F | 0 | 5850.59 | 585059 | 100 | OPC A |  |  |  |  |  |  |  |  |  |  |  |  |  |  |  |
| 1363015a |  | Update Hi-Level Applications Labor FY12 | 367d | 2011-10-03 A | 2013-08-30 A | 1363015 | 100% | 2011-10-03 | 2013-03-29 |  | COMP SCIENT [1206.4 h] | 79,988.4 | 80,372.81 |  |  | 63093.682496 | 79163.968 | BICKLEY M | 1 | 1 | S | MIKE S |  |  |  | 08-016 | 08-052 | 09-012 | 10-070 | 11-038 | 12-029F |  |  |  |  | OPC A | ST | 12-053 |  |  |  |  |  |  |  |  |  |  |  |  |  |
| 1363015aa |  | Update Hi-Level Applications Labor FY13 | 367d | 2011-10-03 A | 2013-08-30 A | 1363015a FS-140d | 100% | 2011-10-03 | 2013-03-29 |  | COMP SCIENT [586.1 h] | 38,860.41 | 39,047.86 |  |  | 31628.810307 | 39684.831 | BICKLEY M | 1 | 1 | S | MIKE S |  |  |  | 08-016 | 08-052 | 09-012 | 10-070 | 11-038 | 12-029F |  |  |  |  |  | ST | 12-053 |  |  |  |  |  |  |  |  |  |  |  |  |  |
| 1363912LOE |  | FY12 CSS Sys Mngmnt Effort | 247d | 2011-10-03 A | 2012-09-28 A | 1363911LOE | 100% |  |  |  | SR STAFF [24 h] | 2,712 | 2,712 | 100 | 100 | 0 | 2712 | BICKLEY M | 1 | 1 | E | MIKE S |  | 7.69230769 | 92.3076923 |  |  |  |  |  |  |  |  |  |  |  |  |  |  |  |  |  |  |  |  |  |  |  |  |  |  |
| 1363020 |  | Update Sys Tools (CONT SYS SW) FY12 | 219d | 2012-02-13 A | 2013-03-11 A | 9-120M | 100% | 2012-02-13 | 2012-12-21 |  | COMP SCIENT [440.97 h] | 29,180.54 | 29,301.75 |  |  | 0 | 28936.4514 | BICKLEY M | 1 | 1 | H | MIKE S |  |  |  | 08-016 |  | 09-012 | 10-070 |  | 12-029F |  |  |  |  | OPC A |  | 12-053 | 11-026 | 12-018F | 12-035F | XX |  |  |  |  |  |  |  |  |  |
| 1363020a |  | Update Sys Tools (CONT SYS SW) FY13 | 219d | 2012-02-13 A | 2013-03-11 A | 1363020 FS-80d | 100% | 2012-02-13 | 2012-12-21 |  | COMP SCIENT [239.03 h] | 15,817.46 | 15,883.48 |  |  | 0 | 16184.7213 | BICKLEY M | 1 | 1 | H | MIKE S |  |  |  | 08-016 |  | 09-012 | 10-070 |  | 12-029F |  |  |  |  |  |  | 12-053 | 11-026 | 12-018F | 12-035F | XX |  |  |  |  |  |  |  |  |  |
| 1363020b |  | Update Sys Tools (CONT SYS SW) Procurement | 219d | 2012-02-13 A | 2013-03-11 A | 9-120M | 100% | 2012-02-13 | 2012-12-21 |  | PROCUREMENT<$50K 60 NO ESCALATION FY13 | 11,840.45 |  |  |  | 0 | 11840.45 | BICKLEY M | 1 | 1 | H | MIKE S |  |  |  | 08-016 |  | 09-012 | 10-070 |  | 12-029F | 0 | 11840.45 | 1184045 | 100 |  |  | 12-053 | 11-026 | 12-018F | 12-035F | XX |  |  |  |  |  |  |  |  |  |
| 1363035 |  | Integration with Sys administration Mngmnt Software (CONT SYS SW) | 211d | 2012-02-13 A | 2013-01-28 A | 2-02M FS-60d | 100% | 2012-02-13 | 2012-12-11 |  | COMP SCIENT [80 h]; SUPPLIES & MATERIALS | 14,953.46 | 5,303.69 |  |  | 0 | 14913.84 | BICKLEY M | 1 | 1 | H | MIKE S |  |  |  |  |  |  |  |  | 12-029F |  |  |  |  |  |  |  | 11-026 | 12-018F | 12-035F | XX | 10-031 |  |  |  |  |  |  |  |  |
| 1363025 |  | Update Low-Level Applications (CONT SYS SW) FY12 | 205d | 2012-04-02 A | 2013-08-30 A | 9-120M FS+140d | 100% | 2012-04-02 | 2013-01-29 |  | COMP SCIENT [254.49 h]; SUPPLIES & MATERIALS | 21,368.28 | 17,041.24 |  |  | 4233.18076 | 21165.9038 | BICKLEY M | 1 | 1 | S | MIKE S |  |  |  |  |  |  | 10-070 |  |  |  |  |  |  | OPC A | ST | 12-053 |  |  |  | XX | 10-031 | 10-064 |  |  |  |  |  |  |  |
| 1363025a |  | Update Low-Level Applications (CONT SYS SW) FY13 | 203d | 2012-04-04 A | 2013-08-30 A | 1363025 FS-100d | 100% | 2012-04-04 | 2013-01-29 |  | COMP SCIENT [185.51 h]; SUPPLIES & MATERIALS | 15,681.78 | 12,423.59 |  |  | 3184.10442 | 15920.5221 | BICKLEY M | 1 | 1 | S | MIKE S |  |  |  |  |  |  | 10-070 |  |  |  |  |  |  |  | ST | 12-053 |  |  |  | XX | 10-031 | 10-064 |  |  |  |  |  |  |  |
| 1363025b |  | Update Low-Level Applications (CONT SYS SW) Procurement | 203d | 2012-04-04 A | 2013-08-30 A | 9-120M FS+140d | 100% | 2012-04-04 | 2013-01-29 |  | PROCUREMENT<$50K 60 NO ESCALATION FY13 | 19,316.81 |  |  |  | 3863.362 | 19316.81 | BICKLEY M | 1 | 1 | S | MIKE S |  |  |  |  |  |  | 10-070 |  |  | 0 | 19316.81 | 1931681 | 100 |  | ST | 12-053 |  |  |  | XX | 10-031 | 10-064 |  |  |  |  |  |  |  |
| 1363014 |  | Update Synoptic Displays (CONT SYS SW) FY12 | 136d | 2012-06-02 A | 2013-03-11 A | 2-02M | 100% | 2012-06-05 | 2012-12-14 |  | COMP SCIENT [517.33 h] | 34,368.55 | 34,551.6 |  |  | 0 | 33947.1946 | BICKLEY M | 1 | 1 | H | MIKE S |  |  |  |  |  |  |  |  |  |  |  |  |  | OPC A |  | 12-053 |  |  |  | XX |  |  |  |  |  |  |  |  |  |
| 1363014a |  | Update Synoptic Displays (CONT SYS SW) FY13 | 136d | 2012-06-02 A | 2013-03-11 A | 1363014 FS-80d | 100% | 2012-06-05 | 2012-12-14 |  | COMP SCIENT [282.67 h] | 18,779.04 | 18,880.14 |  |  | 0 | 19139.5857 | BICKLEY M | 1 | 1 | H | MIKE S |  |  |  |  |  |  |  |  |  |  |  |  |  |  |  | 12-053 |  |  |  | XX |  |  |  |  |  |  |  |  |  |
| 1363913LOE |  | FY13 CSS Sys Mngmnt Effort | 248d | 2012-10-01 A | 2013-08-30 A | 1363912LOE | 100% | 2012-10-01 | 2013-09-30 |  | SR STAFF [22.06 h] | 2,572.2 | 2,572.2 | 100 | 100 | 474.04872114 | 2572.196 | BICKLEY M | 1 | 1 | E | MIKE S |  | 8.06451612 | 91.93548387 |  |  |  |  |  |  |  |  |  |  | OPC A |  |  |  |  |  |  |  |  |  |  |  |  |  |  |  |
| 1363030 |  | Update Communication/Coordination Tools (CONT SYS SW) FY12 | 38d | 2012-11-12 A | 2013-03-11 A | 12163050M, 9-120M FS+230d | 100% | 2012-11-12 | 2013-01-14 |  | COMP SCIENT [40 h] | 2,708.4 | 2,708.4 |  |  | 0 | 2624.8 | BICKLEY M | 1 | 1 | H | MIKE S |  |  |  |  |  |  | 10-070 |  |  |  |  |  |  | OPC A |  | 12-053 |  |  |  | XX |  |  |  |  |  |  |  |  |  |
| 1363030a |  | Update Communication/Coordination Tools (CONT SYS SW) FY13 | 38d | 2012-11-12 A | 2013-03-11 A | 1363030 FS-30d | 100% | 2012-11-12 | 2013-01-14 |  | COMP SCIENT [160 h] | 10,833.6 | 10,833.6 |  |  | 0 | 10833.6 | BICKLEY M | 1 | 1 | H | MIKE S |  |  |  |  |  |  | 10-070 |  |  |  |  |  |  |  |  | 12-053 |  |  |  | XX |  |  |  |  |  |  |  |  |  |
| 1363950 |  | Re-Baseline Actuals Adjustment | 1d | 2013-08-30 A | 2013-08-30 A |  | 100% | 2013-09-03 | 2013-09-03 |  | PROCUREMENT>$50K 69 NO ESCALATION | -60,622.95 |  |  |  |  |  |  |  |  |  |  |  |  |  |  |  |  |  |  |  |  |  |  | 100 |  |  |  |  |  |  |  |  |  | ADJ |  |  |  |  |  |  |
| 2363015aa |  | Update Hi-Level Applications Labor | 20d | 2013-09-03 A | 2013-10-21 A | 9-130M FS+228d | 100% | 2013-10-01 | 2013-10-28 | 8/5 M-F w/JLAB Holidays ReBaseline | COMP SCIENT [296.2 h] | 20,695.49 | 20,458.53 |  |  |  | 20055.702 | BICKLEY M | 1 | 1 | S | MIKE S |  |  |  | 08-016 | 08-052 | 09-012 | 10-070 | 11-038 | 12-029F |  |  |  |  |  | ST | 12-053 |  |  |  |  |  |  |  | 2363015aa | PE | NO | 13-015 | PR |  |
| 2363913LOE |  | FY13 CSS Sys Mngmnt Effort | 20d | 2013-09-03 A | 2013-09-30 A | 9-130M FS+228d | 100% | 2013-10-01 | 2013-10-28 | 8/5 M-F w/JLAB Holidays ReBaseline | SR STAFF [1.93 h] | 232.22 | 225.04 | 100 | 100 |  | 0 | BICKLEY M | 1 | 1 | E | MIKE S |  |  |  |  |  |  |  |  |  |  |  |  |  |  |  |  |  |  |  |  |  |  |  | 2363913LOE | PE |  | 13-015 | PR | 225.038 |

Notes:
- 1363015: Entry Criteria: Ext Pred: Beamline design / finalized
- 1363015b: Entry Criteria: Ext Pred: Beamline design / finalized
- 1363015a: Entry Criteria: Ext Pred: Beamline design / finalized / Steps: Hall D Beamline Orbit lock Design (done); ARC 10 Orbit lock Design (done); Integrate new C-100s into LEM Design (done); Harp Analyzer Design (done); Krest Design (done); SpinMotor Design (done); Hall D Beamline Orbit lock Implementation (done); ARC 10 Orbit lock Implementation (done); Hall D Energy lock Implementation (done); Integrate new C-100s into LEM Implementation (done); Harp Analyzer Implementation (done); Krest Implementation (done); Maxjuice Implementation (done); SpinMotor Implementation (done); Hall D Beamline Orbit lock Test (done); ARC 10 Orbit lock Test (done); Hall D Energy lock Test (done); Integrate new C-100s into LEM Test (done); Harp Analyzer Test (done); Krest Test (done); Maxjuice Test (done); SpinMotor Test (done)
- 1363015aa: Entry Criteria: Ext Pred: Beamline design / finalized / Steps: Hall D Beamline Orbit lock Design (done); ARC 10 Orbit lock Design (done); Integrate new C-100s into LEM Design (done); Harp Analyzer Design (done); Krest Design (done); SpinMotor Design (done); Hall D Beamline Orbit lock Implementation (done); ARC 10 Orbit lock Implementation (done); Hall D Energy lock Implementation (done); Integrate new C-100s into LEM Implementation (done); Harp Analyzer Implementation (done); Krest Implementation (done); Maxjuice Implementation (done); SpinMotor Implementation (done); Hall D Beamline Orbit lock Test (done); ARC 10 Orbit lock Test (done); Hall D Energy lock Test (done); Integrate new C-100s into LEM Test (done); Harp Analyzer Test (done); Krest Test (done); Maxjuice Test (done); SpinMotor Test (done)
- 1363025: Corrective Actions: pred of beamline final / designed / Explanation: "H" assigned when originated 50K / Steps: Add Hall D beam time accounting logic (done); Add Hall D lock placeholders and logic (done); Add Hall D autologging placeholders and logic (done); Add Hall D BOOM placeholders and logic (done); Integrate Hall D into application development tools (done)
- 1363025a: Corrective Actions: pred of beamline final / designed / Steps: Add Hall D beam time accounting logic (done); Add Hall D lock placeholders and logic (done); Add Hall D autologging placeholders and logic (done); Add Hall D BOOM placeholders and logic (done); Integrate Hall D into application development tools (done)
- 1363025b: Corrective Actions: pred of beamline final / designed / Steps: Add Hall D beam time accounting logic (done); Add Hall D lock placeholders and logic (done); Add Hall D autologging placeholders and logic (done); Add Hall D BOOM placeholders and logic (done); Integrate Hall D into application development tools (done)
- 1363014: Corrective Actions: Review Potential Successors
- 1363014a: Corrective Actions: Review Potential Successors
- 2363015aa: Entry Criteria: Ext Pred: Beamline design / finalized / Steps: Update Hi-Level Applications Labor (done)

| ID | WBS | Activity | Type | Duration | Start | Finish | Predecessors | Complete | Remaining | Planned start | Planned finish | Total float | Free float | Calendar | Resources | Cost | Actual cost | LOE Divider | LOE Multiplier | Calculated Remaining Total Cost | MONTHLY EV COST | RESP - Responsibility | STRT%COMP for CM EVM | FNSH%COMP for CM EVM | EVMS Reporting Codes | CAM RESPONSIBLE | CR 08-058 | LOE % Pre Calc | LOE % | Remaining Material Cost Based on % Compl | Claimed Material Cost Based on % Complet | Initial Claimed Material Calc | Claimed Material Divider | CR 10-031 | CR 12-037 | CR 12-001 | MARCH!!! | CR 10-065 | Installation | OPC Allison | CR 12-053 | CR 09-015 | CR 13-003 | Activities with Steps | ReBaseline Actuals Adjustment | Milestone Level | Original Activity ID Rebaseline | PRIOR MONTH EV COST | BOE Labor | BOE Adder | Post Rebaseline | CR 13-015 | CR 14-001 | Obligated Prior to Rebaseline |
| --- | --- | --- | --- | --- | --- | --- | --- | --- | --- | --- | --- | --- | --- | --- | --- | --- | --- | --- | --- | --- | --- | --- | --- | --- | --- | --- | --- | --- | --- | --- | --- | --- | --- | --- | --- | --- | --- | --- | --- | --- | --- | --- | --- | --- | --- | --- | --- | --- | --- | --- | --- | --- | --- | --- |
|  | 4 | **1.3.6.4 SAFETY SYSTEMS** |  |  | 2009-01-02 | 2014-06-02 |  |  |  |  |  |  |  |  |  |  |  |  |  |  |  |  |  |  |  |  |  |  |  |  |  |  |  |  |  |  |  |  |  |  |  |  |  |  |  |  |  |  |  |  |  |  |  |  |
|  | 1 | **1.3.6.4.1 MACHINE PROTECTION** |  |  | 2009-01-02 | 2014-06-02 |  |  |  |  |  |  |  |  |  |  |  |  |  |  |  |  |  |  |  |  |  |  |  |  |  |  |  |  |  |  |  |  |  |  |  |  |  |  |  |  |  |  |  |  |  |  |  |  |
| 13641909LOE |  | FY09 Mngmnt & Elect Dsgn Supprt Effort for MPS |  | 189d | 2009-01-02 A | 2009-09-30 A | 13641909LOEX | 100% |  |  |  |  |  |  | ELEC DES [3.05 h]; SR STAFF [3.05 h] | 453.9 | 453.9 | 100 | 100 | 0 | 453.90017 | MAHONEY K | 1 | 1 | E | MIKE S | 08-058 |  |  |  |  |  |  |  |  |  |  |  |  |  |  |  |  |  |  |  |  |  |  |  |  |  |  |  |
| 13641910LOE |  | FY10 Mngmnt & Elect Dsgn Supprt Effort for MPS |  | 248d | 2009-10-01 A | 2010-09-30 A | 13641909LOE | 100% |  |  |  |  |  |  | ELEC DES [4 h]; SR STAFF [4 h] | 614.24 | 614.24 | 100 | 100 | 0 | 614.24 | MAHONEY K | 1 | 1 | E | MIKE S |  |  |  |  |  |  |  |  |  |  |  |  |  |  |  |  |  |  |  |  |  |  |  |  |  |  |  |  |
| 13641911LOE |  | FY11 Mngmnt & Elect Dsgn Supprt Effort for MPS |  | 248d | 2010-10-01 A | 2011-09-30 A | 13641910LOE | 100% |  |  |  |  |  |  | ELEC DES [64 h]; SR STAFF [36 h] | 7,075.16 | 7,075.16 | 100 | 100 | 0 | 7075.16 | MAHONEY K | 1 | 1 | E | MIKE S |  | 8.46774193 | 91.53225806 |  |  |  |  |  |  |  |  |  |  |  |  |  |  |  |  |  |  |  |  |  |  |  |  |  |
| 13641014a |  | Proc Wire & Cable for RF Installation (MPS) |  | 14d | 2011-02-01 A | 2011-02-21 A | 9-110M FS+68d | 100% |  | 2011-02-01 | 2011-02-18 |  |  |  | PROCUREMENT<$50K 60; ELEC TECH [18 h]; ELEC ENG [20 h] | 3,685.31 | 2,137.46 |  |  | 0 | 3685.31 | MAHONEY K | 1 | 1 | D | MIKE S |  |  |  | 0 | 1547.85 | 154785 | 100 | 10-031 | 12-037F |  |  |  |  |  |  |  |  |  |  |  |  |  |  |  |  |  |  |  |
| 13641015a |  | Proc FSD Hardware for RF Installation (MPS) |  | 105d | 2011-02-25 A | 2011-07-25 A | 13641014a | 100% |  |  |  |  |  |  | ELEC TECH [18 h]; PROCUREMENT<$50K 60; ELEC ENG [20 h] | 5,336.35 | 2,137.46 |  |  | 0 | 5336.35 | MAHONEY K | 1 | 1 | D | MIKE S |  |  |  | 0 | 3198.89 | 319889 | 100 | 10-031 | 12-037F |  |  |  |  |  |  |  |  |  |  |  |  |  |  |  |  |  |  |  |
| 13641025a |  | Install FSD Wire & Cable for RF Installation (MPS) FY11 |  | 112d | 2011-03-01 A | 2011-08-05 A | 13641020a FS-60d | 100% |  |  |  |  |  |  | ELEC TECH [31.73 h]; PLABOR; ELEC ENG [5.44 h] | 1,962.98 | 1,729.08 |  |  | 0 | 1962.9793 | MAHONEY K | 1 | 1 | H | MIKE S |  |  |  |  |  |  |  | 10-031 | 12-037F | 12-001 |  |  |  |  |  |  |  |  |  |  |  |  |  |  |  |  |  |  |
| 13641025ab |  | Install FSD Wire & Cable for RF Installation (MPS) FY12 |  | 112d | 2011-03-01 A | 2011-08-05 A | 13641025a | 100% |  |  |  |  |  |  | ELEC TECH [38.27 h]; PLABOR; ELEC ENG [6.56 h] | 2,376.43 | 2,085.38 |  |  | 0 | 2442.7787 | MAHONEY K | 1 | 1 | H | MIKE S |  |  |  |  |  |  |  | 10-031 | 12-037F | 12-001 |  |  |  |  |  |  |  |  |  |  |  |  |  |  |  |  |  |  |
| 13641020a |  | Test/QA FSD Hardware for RF Installation (MPS) |  | 85d | 2011-05-13 A | 2011-09-13 A | 13641015a FS-35d | 100% |  |  |  |  |  |  | ELEC ENG [40 h]; ELEC TECH [96 h] | 6,841.12 | 6,841.12 |  |  | 0 | 6841.12 | MAHONEY K | 1 | 1 | H | MIKE S |  |  |  |  |  |  |  | 10-031 | 12-037F |  |  |  |  |  |  |  |  |  |  |  |  |  |  |  |  |  |  |  |
| 13641030a |  | Install/Test FSD Hardware for RF Installation(MPS) |  | 393d | 2011-05-23 A | 2013-08-30 A | 13641025ab FS-250d | 100% |  | 2011-05-23 | 2012-12-17 |  |  |  | ELEC TECH [32 h]; ELEC ENG [16 h] | 2,533.91 | 2,561.02 |  |  | 1270.56 | 2541.12 | MAHONEY K | 1 | 1 | H | MIKE S |  |  |  |  |  |  |  | 10-031 | 12-037F |  | XX |  |  |  |  |  |  |  |  |  |  |  |  |  |  |  |  |  |
| 13641912LOE |  | FY12 Mngmnt & Elect Dsgn Supprt Effort for MPS |  | 247d | 2011-10-03 A | 2012-09-28 A | 13641911LOE | 100% |  |  |  |  |  |  | SR STAFF [36 h]; ELEC DES [64 h] | 7,300.64 | 7,300.64 | 100 | 100 | 0 | 7300.64 | MAHONEY K | 1 | 1 | E | MIKE S |  | 7.69230769 | 92.3076923 |  |  |  |  |  |  |  |  |  |  |  |  |  |  |  |  |  |  |  |  |  |  |  |  |  |
| 13641014 |  | Proc Wire & Cable (MPS) |  | 200d | 2012-01-03 A | 2012-10-15 A | 121641110M, 9-120M FS+60d, 121641170 | 100% |  |  |  |  |  |  | PROCUREMENT<$50K 60; ELEC TECH [20.77 h]; ELEC ENG [20.77 h] | 43,049.67 | 2,386.29 |  |  | 0 | 43045.4913 | MAHONEY K | 1 | 1 | D | MIKE S |  |  |  | 0 | 40663.38 | 4066338 | 100 | 10-031 | 12-037F |  |  |  |  |  |  |  |  |  |  |  |  |  |  |  |  |  |  |  |
| 13641050 |  | Proc BLM Hardware (MPS) |  | 242d | 2012-02-01 A | 2013-08-28 A | 9-120M | 100% |  | 2012-02-01 | 2013-01-22 |  |  |  | ELEC TECH [80 h]; PROCUREMENT<$50K 60; ELEC ENG [40 h] | 49,037.3 | 6,468.83 |  |  | 24488.06 | 48976.12 | MAHONEY K | 1 | 1 | H | MIKE S |  |  |  | 0 | 42623.32 | 4262332 | 100 |  | 12-037F |  | XX | 10-065 |  |  |  |  |  |  |  |  |  |  |  |  |  |  |  |  |
| 13641035 |  | Develop/Install/Test FSD Firmware (MPS) |  | 220d | 2012-02-06 A | 2013-08-26 A | 13641025b FS-190d, 13641030 FS-190d | 100% |  | 2012-02-06 | 2012-12-17 |  |  |  | ELEC ENG [200 h] | 14,222.45 | 14,370.46 |  |  | 7281 | 14562 | MAHONEY K | 1 | 1 | H | MIKE S |  |  |  |  |  |  |  |  | 12-037F |  | XX |  | Install | OPC A |  |  |  |  |  |  |  |  |  |  |  |  |  |  |
| 13641015 |  | Proc FSD Hardware (MPS) |  | 132d | 2012-07-02 A | 2013-08-28 A | 13641014 FS-60d, 121641110M, 121641170 | 100% |  | 2012-07-02 | 2013-01-14 |  |  |  | ELEC TECH [20.77 h]; PROCUREMENT<$50K 60; ELEC ENG [20.77 h] | 13,605.01 | 2,441.35 |  |  | 6782.92065 | 13565.8413 | MAHONEY K | 1 | 1 | D | MIKE S |  |  |  | 0 | 11183.73 | 1118373 | 100 | 10-031 | 12-037F |  | XX |  |  |  |  |  |  |  |  |  |  |  |  |  |  |  |  |  |
| 13641020 |  | Test/QA FSD Hardware (MPS) FY12 |  | 83d | 2012-09-14 A | 2013-08-28 A | 13641015 FS-30d | 100% |  | 2012-09-14 | 2013-01-18 |  |  |  | ELEC ENG [14.19 h]; ELEC TECH [21.29 h] | 1,994.51 | 1,999.84 |  |  | 970.38705 | 1940.7741 | MAHONEY K | 1 | 1 | H | MIKE S |  |  |  |  |  |  |  | 10-031 | 12-037 |  | XX |  |  | OPC A | 12-053 |  |  |  |  |  |  |  |  |  |  |  |  |  |
| 13641020b |  | Test/QA FSD Hardware (MPS) FY13 |  | 83d | 2012-09-14 A | 2013-08-19 A | 13641020 FS-70d | 100% |  | 2012-09-14 | 2013-01-18 |  |  |  | ELEC TECH [21.29 h]; ELEC ENG [14.19 h] | 1,994.51 | 1,999.76 |  |  | 1001.36025 | 2002.7205 | MAHONEY K | 1 | 1 | H | MIKE S |  |  |  |  |  |  |  | 10-031 | 12-037 |  | XX |  |  |  | 12-053 |  |  |  |  |  |  |  |  |  |  |  |  |  |
| 13641085 |  | Proc Tagger/Hall D Beam Loss Monitoring Hardware (MPS) |  | 66d | 2012-10-01 A | 2013-08-30 A | 9-130M FS+20d, 9-120M FS+235d | 100% |  | 2012-10-01 | 2013-01-10 |  |  |  | ELEC ENG [40 h]; ELEC TECH [40 h]; PROCUREMENT<$50K 60 | 31,983.88 | 4,734 |  |  | 15918.74 | 31837.48 | MAHONEY K | 1 | 1 | H | MIKE S |  |  |  | 0 | 27249.88 | 2724988 | 100 |  | 12-037F |  | XX |  |  |  |  | 09-015 |  |  |  |  |  |  |  |  |  |  |  |  |
| 13641913LOE |  | FY13 Mngmnt & Elect Dsgn Supprt Effort for MPS |  | 248d | 2012-10-01 A | 2013-08-30 A | 13641912LOE | 100% |  | 2012-10-01 | 2013-09-30 |  |  |  | ELEC DES [58.84 h]; SR STAFF [33.1 h] | 6,926.09 | 6,932.88 | 100 | 100 | 1276.137632 | 6926.097632 | MAHONEY K | 1 | 1 | E | MIKE S |  | 8.06451612 | 91.93548387 |  |  |  |  |  |  |  |  |  |  | OPC A |  |  |  |  |  |  |  |  |  |  |  |  |  |  |
| 13641070 |  | Develop/Install/Test BLM Firmware (MPS) |  | 67d | 2013-01-07 A | 2013-07-15 A | 13641065 FS-120d | 100% |  | 2013-02-01 | 2013-05-07 |  |  |  | ELEC ENG [160 h] | 11,649.6 | 11,649.6 |  |  | 5824.8 | 11649.6 | MAHONEY K | 1 | 1 | H | MIKE S |  |  |  |  |  |  |  |  | 12-037 |  |  |  | Install | OPC A |  |  |  |  |  |  |  |  |  |  |  |  |  |  |
| 13641090 |  | Test/QA Tagger/Hall D Beam Loss Monitoring Hardware (MPS) |  | 20d | 2013-02-14 A | 2013-08-30 A | 13641085 FS-70d | 100% |  | 2013-03-14 | 2013-04-10 |  |  |  | ELEC TECH [80 h]; ELEC ENG [40 h] | 6,555.6 | 6,555.6 |  |  | 3176.4 | 6352.8 | MAHONEY K | 1 | 1 | H | MIKE S |  |  |  |  |  |  |  |  | 12-037F |  | XX |  |  |  |  | 09-015 |  |  |  |  |  |  |  |  |  |  |  |  |
| 13641055 |  | Test/QA BLM Hardware (MPS) |  | 4d | 2013-02-22 A | 2013-08-30 A | 13641050 FS-45d | 100% |  | 2013-03-01 | 2013-03-06 |  |  |  | ELEC ENG [40 h]; ELEC TECH [80 h] | 6,555.6 | 6,555.6 |  |  | 3176.4 | 6352.8 | MAHONEY K | 1 | 1 | H | MIKE S |  |  |  |  |  |  |  |  | 12-037F |  | XX |  |  |  |  |  |  |  |  |  |  |  |  |  |  |  |  |  |
| 13641014b |  | Proc Remaining Wire & Cable (MPS) |  | 44d | 2013-04-01 A | 2013-06-17 A | 9-130M FS+100d | 100% |  | 2013-05-01 | 2013-07-02 |  |  |  | PROCUREMENT<$50K 60 | 8,100 |  |  |  | 0 | 8100 | MAHONEY K | 1 | 1 | D | MIKE S |  |  |  | 0 | 8100 | 810000 | 100 | 10-031 | 12-037F |  |  |  |  |  |  |  | 13-003 |  |  |  |  |  |  |  |  |  |  |  |
| 13641040 |  | Develop/Install/Test FSD Software (MPS) |  | 25d | 2013-06-03 A | 2013-08-30 A | 13641030 FS-80d | 100% |  | 2013-07-31 | 2013-09-04 |  |  |  | COMP SCIENT [40 h] | 2,708.4 | 2,708.4 |  |  | 1354.2 | 2708.4 | MAHONEY K | 1 | 1 | H | MIKE S |  |  |  |  |  |  |  |  | 12-037 |  | XX |  | Install | OPC A |  |  |  |  |  |  |  |  |  |  |  |  |  |  |
| 13641060 |  | Install BLM Wire & Cable (MPS) |  | 84d | 2013-06-03 A | 2013-08-30 A | 16332010U, 16332030, 16333030 FS-125d, 16332010, 13641050 FS-20d | 100% |  | 2013-07-30 | 2013-11-25 |  |  |  | PLABOR; ELEC TECH [320 h]; ELEC ENG [80 h] | 31,987 | 20,397.6 |  |  | 15838.835 | 31677.67 | MAHONEY K | 1 | 1 | H | MIKE S |  |  |  |  |  |  |  |  | 12-037 |  |  |  | Install | OPC A |  |  |  |  |  |  |  |  |  |  |  |  |  |  |
| 13641075 |  | Develop/Install/Test BLM Software (MPS) |  | 48d | 2013-06-03 A | 2013-08-30 A | 13641065 FS-70d | 100% |  | 2013-07-10 | 2013-09-16 |  |  |  | COMP SCIENT [80 h] | 5,416.8 | 5,416.8 |  |  | 2708.4 | 5416.8 | MAHONEY K | 1 | 1 | H | MIKE S |  |  |  |  |  |  |  |  | 12-037 |  |  |  | Install | OPC A |  |  |  |  |  |  |  |  |  |  |  |  |  |  |
| 13641025 |  | Install FSD Wire & Cable (MPS) FY12 |  | 51d | 2013-08-30 A | 2013-08-30 A | 16332010U, 16332010, 13641014, 16332030, 9-130M FS+100d, 3A-08M | 100% |  | 2013-09-03 | 2013-11-12 |  |  |  | ELEC ENG [25.81 h]; ELEC TECH [154.88 h]; PLABOR | 13,611.62 | 8,932.47 |  |  | 13162.268 | 13162.268 | MAHONEY K | 1 | 1 | S | MIKE S |  |  |  |  |  |  |  | 10-031 | 12-037F |  |  |  |  | OPC A | 12-053 |  |  | ST |  |  |  |  |  |  |  |  |  |  |
| 13641025b |  | Install FSD Wire & Cable (MPS) FY13 |  | 13d | 2013-08-30 A | 2013-08-30 A | 13641025 FS-13d | 100% |  | 2013-10-25 | 2013-11-12 |  |  |  | ELEC TECH [14.7 h]; PLABOR; ELEC ENG [2.45 h] | 1,316.06 | 847.82 |  |  | 1289.0625 | 1289.0625 | MAHONEY K | 1 | 1 | S | MIKE S |  |  |  |  |  |  |  | 10-031 | 12-037F |  |  |  |  |  | 12-053 |  |  | ST |  |  |  |  |  |  |  |  |  |  |
| 13641030 |  | Install/Test FSD Hardware (MPS) |  | 8d | 2013-08-30 A | 2013-08-30 A | 13641020b FS+54d, 16332030, 1362020 | 100% |  | 2013-11-05 | 2013-11-14 |  |  |  | ELEC ENG [64 h]; ELEC TECH [128 h] | 10,823.04 | 10,488.96 |  |  | 10488.96 | 10488.96 | MAHONEY K | 1 | 1 | H | MIKE S |  |  |  |  |  |  |  | 10-031 | 12-037 |  |  |  |  | OPC A |  |  |  |  |  |  |  |  |  |  |  |  |  |  |
| 13641065 |  | Install BLM Hardware (MPS) |  | 11d | 2013-08-30 A | 2013-08-30 A | 1362020, 9-130M FS+90d, 13641055 FS+35d, 16332030 | 100% |  | 2013-11-19 | 2013-12-05 |  |  |  | ELEC TECH [160 h]; ELEC ENG [40 h] | 10,523.6 | 10,198.8 |  |  | 10198.8 | 10198.8 | MAHONEY K | 1 | 1 | H | MIKE S |  |  |  |  |  |  |  |  | 12-037 |  |  |  | Install | OPC A |  |  |  |  |  |  |  |  |  |  |  |  |  |  |
| 13641095 |  | Install/Test Tagger/Hall D Beam Loss Monitoring Sys (MPS) |  | 37d | 2013-08-30 A | 2013-08-30 A | 16332010U, 16332030, 13641090 FS-10d, 16333030, 9-130M FS+67d, 16332010 | 100% |  | 2013-12-18 | 2014-02-18 |  |  |  | ELEC TECH [120 h]; ELEC ENG [40 h] | 8,644 | 8,377.2 |  |  | 8377.2 | 8377.2 | MAHONEY K | 1 | 1 | H | MIKE S |  |  |  |  |  |  |  |  | 12-037 |  |  |  | Install | OPC A |  | 09-015 |  |  |  |  |  |  |  |  |  |  |  |  |
| 13641950 |  | Re-Baseline Actuals Adjustment |  | 1d | 2013-08-30 A | 2013-08-30 A |  | 100% |  | 2013-09-03 | 2013-09-03 |  |  |  | PROCUREMENT>$50K 69 NO ESCALATION | -101,820.84 |  |  |  |  |  |  |  |  |  |  |  |  |  |  |  |  | 100 |  |  |  |  |  |  |  |  |  |  |  | ADJ |  |  |  |  |  |  |  |  |  |
| 13641045M |  | FSD Sys Comp (MPS) | milestone | 0d | 2013-08-30 A | 2013-08-30 A | 13641040, 13641035, 13641030a | 100% |  | 2013-10-08 | 2013-10-08 |  |  |  |  |  |  |  |  |  | 0 | MAHONEY K | 1 | 1 | M | MIKE S |  |  |  |  |  |  |  |  | 12-037 |  | XX |  |  | OPC A |  |  |  |  |  | 6 |  |  |  |  |  |  |  |  |
| 13641080M |  | BLM Sys Comp (MPS) | milestone | 0d | 2013-08-30 A | 2013-08-30 A | 13641075, 13641070, 13641014b, 13641060 | 100% |  | 2013-10-29 | 2013-10-29 |  |  |  |  |  |  |  |  |  | 0 | MAHONEY K | 1 | 1 | M | MIKE S |  |  |  |  |  |  |  |  | 12-037 |  |  |  |  | OPC A |  |  |  |  |  | 6 |  |  |  |  |  |  |  |  |
| 13641100M |  | Beam Loss Ion Chamb Sys Comp (MPS) | milestone | 0d | 2013-08-30 A | 2013-08-30 A | 13641095 | 100% |  | 2014-02-18 | 2014-02-18 |  |  |  |  |  |  |  |  |  | 0 | MAHONEY K | 1 | 1 | M | MIKE S |  |  |  |  |  |  |  |  | 12-037 |  |  |  |  | OPC A |  |  |  |  |  | 6 |  |  |  |  |  |  |  |  |
| 23641020 |  | Test/QA FSD Hardware (MPS) |  | 9d | 2013-09-03 A | 2013-09-27 A | 9-130M FS+228d | 100% |  | 2013-10-01 | 2013-10-11 |  |  | 8/5 M-F w/JLAB Holidays ReBaseline | ELEC TECH [20 h]; ELEC ENG [10 h] | 1,691.1 | 1,638.9 |  |  |  | 0 | MAHONEY K | 1 | 1 | S | MIKE S |  |  |  |  |  |  |  | 10-031 | 12-037 |  |  |  |  |  | 12-053 |  |  | ST |  |  | 23641020 | 1638.9 | PE | NO | PR |  |  |  |
| 23641040 |  | Develop/Install/Test FSD Software (MPS) FY13 |  | 34d | 2013-09-03 A | 2013-10-21 A | 9-130M FS+237d | 100% |  | 2013-10-01 | 2013-11-15 |  |  | 8/5 M-F w/JLAB Holidays ReBaseline | COMP SCIENT [25.88 h] | 1,808.24 | 1,795.19 |  |  |  | 438.0837 | MAHONEY K | 1 | 1 | S | MIKE S |  |  |  |  |  |  |  |  | 12-037 |  |  |  |  |  |  |  |  | ST |  |  | 23641040 | 1314.2511 | PE | NO | PR | 13-015 |  |  |
| 23641040a |  | Develop/Install/Test FSD Software (MPS) FY14 |  | 23d | 2013-09-03 A | 2013-10-21 A | 23641040 FS-40d | 100% |  | 2013-10-01 | 2013-10-31 |  |  | 8/5 M-F w/JLAB Holidays ReBaseline | COMP SCIENT [54.12 h] | 3,781.36 | 3,745.94 |  |  |  | 945.3411 | MAHONEY K | 1 | 1 | S | MIKE S |  |  |  |  |  |  |  |  | 12-037 |  |  |  |  |  |  |  |  | ST |  |  | 23641040 | 2836.0233 | PE | NO | PR | 13-015 | 14-001 |  |
| 23641055 |  | Test/QA BLM Hardware (MPS) FY13 |  | 25d | 2013-09-03 A | 2013-11-27 | 9-130M FS+228d | 25% | 19d | 2013-10-01 | 2013-11-04 | 99d | 26d | 8/5 M-F w/JLAB Holidays ReBaseline | ELEC ENG [19.2 h]; ELEC TECH [19.2 h] | 2,344.71 | 1,602.81 |  |  |  | 0 | MAHONEY K | 1 | 1 | S | MIKE S |  |  |  |  |  |  |  |  | 12-037F |  |  |  |  |  |  |  |  | ST |  |  | 23641055 | 568.08 | PE | NO | PR | 13-015 |  |  |
| 23641055a |  | Test/QA BLM Hardware (MPS) FY14 |  | 5d | 2013-09-03 A | 2013-11-27 | 23641055 FS-45d | 25% | 19d | 2013-10-01 | 2013-10-07 | 99d | 41d | 8/5 M-F w/JLAB Holidays ReBaseline | ELEC ENG [4.8 h]; ELEC TECH [4.8 h] | 586.17 | 400.71 |  |  |  | 0 | MAHONEY K | 1 | 1 | S | MIKE S |  |  |  |  |  |  |  |  | 12-037F |  |  |  |  |  |  |  |  | ST |  |  | 23641055 | 146.544 | PE | NO | PR | 13-015 | 14-001 |  |
| 23641085 |  | Proc Tagger/Hall D Beam Loss Monitoring Hardware (MPS) |  | 20d | 2013-09-03 A | 2013-11-15 | 9-130M FS+228d | 67% | 11d | 2013-10-01 | 2013-10-28 | 95d | 79d | 8/5 M-F w/JLAB Holidays ReBaseline | PROCUREMENT<$50K 60 | 8,000 |  |  |  |  | 5328 | MAHONEY K | 1 | 1 | S | MIKE S |  |  |  | 2672 | 5328 | 532800 | 100 |  | 12-037 |  |  |  |  |  |  |  |  | ST |  |  | 23641065 |  | PE | NO | PR | 13-015 |  | OB |
| 23641913LOE |  | FY13 Mngmnt & Elect Dsgn Supprt Effort for MPS |  | 20d | 2013-09-03 A | 2013-09-30 A | 9-130M FS+228d | 100% |  | 2013-10-01 | 2013-10-28 |  |  | 8/5 M-F w/JLAB Holidays ReBaseline | ELEC DES [5.16 h]; SR STAFF [2.9 h] | 626.55 | 607.2 | 100 | 100 |  | 0 | MAHONEY K | 1 | 1 | E | MIKE S |  |  |  |  |  |  |  |  |  |  |  |  |  |  |  |  |  |  |  |  | 23641913LOE | 607.19275 | PE | NO | PR | 13-015 |  |  |
| 23641025 |  | Install FSD Wire & Cable (MPS) FY13 |  | 40d | 2013-09-16 A | 2013-11-15 | 9-130M SS+242d | 25% | 11d | 2013-10-01 | 2013-11-25 | 122d | 29d | 8/5 M-F w/JLAB Holidays ReBaseline | ELEC ENG [4.24 h]; ELEC TECH [41.64 h] | 2,275.19 | 1,701.87 |  |  |  | 551.24380975 | MAHONEY K | 1 | 1 | S | MIKE S |  |  |  |  |  |  |  | 10-031 | 12-037F |  |  |  |  |  | 12-053 |  |  | ST |  |  | 23641025 |  | PE | NO | PR | 13-015 |  |  |
| 23641025a |  | Install FSD Wire & Cable (MPS) FY14 |  | 34d | 2013-09-16 A | 2013-11-15 | 23641025 FS-40d | 25% | 11d | 2013-10-01 | 2013-11-15 | 122d | 52d | 8/5 M-F w/JLAB Holidays ReBaseline | ELEC ENG [24.02 h]; ELEC TECH [235.96 h] | 12,892.41 | 9,643.67 |  |  |  | 3223.10213775 | MAHONEY K | 1 | 1 | S | MIKE S |  |  |  |  |  |  |  | 10-031 | 12-037F |  |  |  |  |  | 12-053 |  |  | ST |  |  | 23641025 |  | PE | NO | PR | 13-015 | 14-001 |  |
| 23641030a |  | Install/Test FSD Hardware for RF Installation(MPS) FY13 |  | 34d | 2013-09-16 A | 2013-10-21 A | 9-130M FS+237d | 100% |  | 2013-10-01 | 2013-11-15 |  |  | 8/5 M-F w/JLAB Holidays ReBaseline | ELEC TECH [12.94 h]; ELEC ENG [12.94 h] | 1,580.23 | 1,573.19 |  |  |  | 1225.1592 | MAHONEY K | 1 | 1 | S | MIKE S |  |  |  |  |  |  |  | 10-031 | 12-037F |  |  |  |  |  |  |  |  | ST |  |  | 23641030a | 306.2898 | PE | NO | PR | 13-015 |  |  |
| 23641030aa |  | Install/Test FSD Hardware for RF Installation(MPS) FY14 |  | 23d | 2013-09-16 A | 2013-10-21 A | 23641030a FS-40d | 100% |  | 2013-10-01 | 2013-10-31 |  |  | 8/5 M-F w/JLAB Holidays ReBaseline | ELEC TECH [27.06 h]; ELEC ENG [27.06 h] | 3,304.57 | 3,284.88 |  |  |  | 2643.65376 | MAHONEY K | 1 | 1 | S | MIKE S |  |  |  |  |  |  |  | 10-031 | 12-037F |  |  |  |  |  |  |  |  | ST |  |  | 23641030a | 660.91344 | PE | NO | PR | 13-015 | 14-001 |  |
| 23641100 |  | Rework FSD Cards |  | 35d | 2013-10-01 A | 2013-11-18 | 9-140M | 40% | 12d | 2013-11-01 | 2014-01-02 | 94d | 78d | 8/5 M-F w/JLAB Holidays ReBaseline | PROCUREMENT<$50K 60 | 4,127.6 |  |  |  |  | 1651.04 | MAHONEY K | 1 | 1 | S | MIKE S |  |  |  | 2476.56 | 1651.04 | 165104 | 100 |  | 12-037 |  |  |  |  |  |  |  |  | ST |  |  | 23641065 |  | PE | NO | PR | 13-015 | 14-001 | OB-2 |
| 23641065 |  | Install BLM Hardware (MPS) FY13 |  | 37d | 2013-10-01 A | 2014-01-27 | 23641060 FS-51d, 23641055a FS-60d, 23641055 FS-60d | 33% | 51d | 2013-11-21 | 2014-01-27 | 58d | 0d | 8/5 M-F w/JLAB Holidays ReBaseline | ELEC ENG [6.95 h]; ELEC TECH [27.79 h] | 1,827.95 | 568.14 |  |  |  | 589.92000948 | MAHONEY K | 1 | 1 | S | MIKE S |  |  |  |  |  |  |  |  | 12-037 |  |  |  |  |  |  |  |  | ST |  |  | 23641065 |  | PE | NO | PR | 13-015 |  |  |
| 23641065a |  | Install BLM Hardware (MPS) FY14 |  | 37d | 2013-10-01 A | 2014-01-27 | 23641065 FS-51d, 23641060a FS-57d, 23641055a FS-60d | 33% | 51d | 2013-11-21 | 2014-01-27 | 58d | 0d | 8/5 M-F w/JLAB Holidays ReBaseline | ELEC ENG [12.85 h]; ELEC TECH [51.42 h] | 3,381.76 | 1,051.09 |  |  |  | 1126.12570038 | MAHONEY K | 1 | 1 | S | MIKE S |  |  |  |  |  |  |  |  | 12-037 |  |  |  |  |  |  |  |  | ST |  |  | 23641065 |  | PE | NO | PR | 13-015 | 14-001 |  |
| 23641914LOE |  | FY14 Mngmnt & Elect Dsgn Supprt Effort for MPS |  | 163d | 2013-10-01 A | 2014-06-02 | 23641913LOE | 14% | 140d | 2013-11-01 | 2014-07-03 | 142d |  | 8/5 M-F w/JLAB Holidays ReBaseline | ELEC DES [38.45 h]; SR STAFF [21.63 h] | 4,670.36 | 659.01 | 100 | 100 |  | 658.98816286 | MAHONEY K | 1 | 1 | E | MIKE S |  | 85.88957055 | 14.11042944 |  |  |  |  |  |  |  |  |  |  |  |  |  |  |  |  |  | 23641914LOE |  | PE | NO | PR | 13-015 | 14-001 |  |
| 23641060 |  | Install BLM Wire & Cable (MPS) FY13 |  | 20d | 2013-10-08 A | 2013-11-20 | 9-140M | 56% | 14d | 2013-11-08 | 2013-12-09 | 95d | 6d | 8/5 M-F w/JLAB Holidays ReBaseline | ELEC ENG [8.34 h]; ELEC DES [1.26 h]; ELEC TECH [30.32 h] | 2,119.04 | 1,191.97 |  |  |  | 1141.8232473 | MAHONEY K | 1 | 1 | S | MIKE S |  |  |  |  |  |  |  |  | 12-037 |  |  |  |  |  |  |  |  | ST |  |  | 23641060 |  | PE | NO | PR | 13-015 |  |  |
| 23641060a |  | Install BLM Wire & Cable (MPS) FY14 |  | 12d | 2013-10-08 A | 2013-11-20 | 23641060 FS-20d | 56% | 14d | 2013-12-10 | 2014-01-06 | 101d | 43d | 8/5 M-F w/JLAB Holidays ReBaseline | ELEC ENG [15.42 h]; ELEC DES [2.34 h]; ELEC TECH [56.08 h] | 3,919.6 | 2,204.78 |  |  |  | 2179.29246089 | MAHONEY K | 1 | 1 | S | MIKE S |  |  |  |  |  |  |  |  | 12-037 |  |  |  |  |  |  |  |  | ST |  |  | 23641060 |  | PE | NO | PR | 13-015 | 14-001 |  |
| 23641087 |  | Install BLM Wire & Cable (MPS) Tagger Hall D FY13 |  | 20d | 2013-10-08 A | 2014-01-13 | 9-140M | 56% | 42d | 2013-12-06 | 2014-01-14 | 39d | 0d | 8/5 M-F w/JLAB Holidays ReBaseline | ELEC TECH [84.71 h]; ELEC ENG [22.87 h]; ELEC DES [2.54 h] | 5,835.38 | 1,750.61 |  |  |  | 3144.33588572 | MAHONEY K | 1 | 1 | S | MIKE S |  |  |  |  |  |  |  |  | 12-037 |  |  |  |  |  |  |  |  | ST |  |  | 23641087 |  | PE | NO | PR | 13-015 |  |  |
| 23641087a |  | Install BLM Wire & Cable (MPS) Tagger Hall D FY14 |  | 22d | 2013-10-08 A | 2014-01-13 | 23641087 FS-42d | 56% | 42d | 2014-01-15 | 2014-02-14 | 39d | 0d | 8/5 M-F w/JLAB Holidays ReBaseline | ELEC TECH [275.29 h]; ELEC ENG [74.33 h]; ELEC DES [8.26 h] | 18,964.48 | 5,689.35 |  |  |  | 10544.24761906 | MAHONEY K | 1 | 1 | S | MIKE S |  |  |  |  |  |  |  |  | 12-037 |  |  |  |  |  |  |  |  | ST |  |  | 23641087 |  | PE | NO | PR | 13-015 | 14-001 |  |
| 23641095 |  | Install/Test Tagger/Hall D Beam Loss Monitoring Sys (MPS) |  | 29d | 2013-10-11 A | 2014-02-18 | 23641090a FS-60d, 23641090 FS-40d | 10% | 66d | 2014-01-31 | 2014-03-12 | 39d | 0d | 8/5 M-F w/JLAB Holidays ReBaseline | ELEC TECH [60 h]; ELEC ENG [20 h] | 4,321.95 | 800.37 |  |  |  | 432.1952331 | MAHONEY K | 1 | 1 | S | MIKE S |  |  |  |  |  |  |  |  | 12-037 |  |  |  |  |  |  | 09-015 |  | ST |  |  | 23641095 |  | PE | NO | PR | 13-015 | 14-001 |  |
| 23641030 |  | Install/Test FSD Hardware (MPS) FY13 |  | 20d | 2013-11-11 | 2013-12-10 | 23641020 FS+30d |  |  |  |  | 70d | 0d | 8/5 M-F w/JLAB Holidays ReBaseline | ELEC ENG [19.23 h]; ELEC TECH [24.28 h] | 2,585.63 |  |  |  |  | 0 | MAHONEY K | 1 | 1 | S | MIKE S |  |  |  |  |  |  |  | 10-031 | 12-037 |  |  |  |  |  |  |  |  | ST |  |  | 23641030 |  | PE | NO | PR | 13-015 |  |  |
| 23641090 |  | Test/QA Tagger/Hall D Beam Loss Monitoring Hardware (MPS) FY13 |  | 34d | 2013-11-12 | 2014-01-10 | 23641087a FS-35d, 23641087 FS-35d |  |  |  |  | 39d | 0d | 8/5 M-F w/JLAB Holidays ReBaseline | ELEC ENG [7.62 h]; ELEC TECH [15.24 h] | 1,288.62 |  |  |  |  | 0 | MAHONEY K | 1 | 1 | S | MIKE S |  |  |  |  |  |  |  |  | 12-037F |  |  |  |  |  |  | 09-015 |  | ST |  |  | 23641090 |  | PE | NO | PR | 13-015 |  |  |
| 23641090a |  | Test/QA Tagger/Hall D Beam Loss Monitoring Hardware (MPS) FY14 |  | 34d | 2013-11-12 | 2014-01-10 | 23641087a FS-45d, 23641090 FS-34d |  |  |  |  | 59d | 20d | 8/5 M-F w/JLAB Holidays ReBaseline | ELEC ENG [24.38 h]; ELEC TECH [48.76 h] | 4,122.9 |  |  |  |  | 0 | MAHONEY K | 1 | 1 | S | MIKE S |  |  |  |  |  |  |  |  | 12-037F |  |  |  |  |  |  | 09-015 |  | ST |  |  | 23641090 |  | PE | NO | PR | 13-015 | 14-001 |  |
| 23641030b |  | Install/Test FSD Hardware (MPS) FY14 |  | 37d | 2013-12-11 | 2014-02-12 | 23641030 |  |  |  |  | 70d | 0d | 8/5 M-F w/JLAB Holidays ReBaseline | ELEC ENG [35.57 h]; ELEC TECH [44.92 h] | 4,783.21 |  |  |  |  | 0 | MAHONEY K | 1 | 1 | S | MIKE S |  |  |  |  |  |  |  | 10-031 | 12-037 |  |  |  |  |  |  |  |  | ST |  |  | 23641030 |  | PE | NO | PR | 13-015 | 14-001 |  |
| 23641075 |  | Develop/Install/Test BLM Software (MPS) |  | 24d | 2014-01-28 | 2014-02-28 | 23641065a, 23641065 FS-4d |  |  |  |  | 58d | 0d | 8/5 M-F w/JLAB Holidays ReBaseline | COMP SCIENT [80 h] | 5,589.6 |  |  |  |  | 0 | MAHONEY K | 1 | 1 | S | MIKE S |  |  |  |  |  |  |  |  | 12-037 |  |  |  |  |  |  |  |  | ST |  |  | 23641075 |  | PE | NO | PR | 13-015 | 14-001 |  |
| 23641045M |  | FSD Sys Comp (MPS) | milestone | 0d | 2014-02-12 | 2014-02-12 | 23641030aa, 23641030a, 23641030, 23641040a, 23641025, 23641040, 23641025a, 23641030b |  |  |  |  | 70d | 12d | 8/5 M-F w/JLAB Holidays ReBaseline |  |  |  |  |  |  | 0 | MAHONEY K | 1 | 1 | M | MIKE S |  |  |  |  |  |  |  |  | 12-037 |  |  |  |  |  |  |  |  |  |  | 6 | 23641045M |  |  | NO | PR | 13-015 |  |  |
| 23641100M |  | Beam Loss Ion Chamb Sys Comp (MPS) | milestone | 0d | 2014-02-18 | 2014-02-18 | 23641095 |  |  |  |  | 39d | 23d | 8/5 M-F w/JLAB Holidays ReBaseline |  |  |  |  |  |  | 0 | MAHONEY K | 1 | 1 | M | MIKE S |  |  |  |  |  |  |  |  | 12-037 |  |  |  |  |  |  |  |  |  |  | 6 | 23641100M |  |  | NO | PR | 13-015 |  |  |
| 23641080M |  | BLM Sys Comp (MPS) | milestone | 0d | 2014-02-28 | 2014-02-28 | 23641075, 23641060, 23641060a |  |  |  |  | 58d | 0d | 8/5 M-F w/JLAB Holidays ReBaseline |  |  |  |  |  |  | 0 | MAHONEY K | 1 | 1 | M | MIKE S |  |  |  |  |  |  |  |  | 12-037 |  |  |  |  |  |  |  |  |  |  | 6 | 23641080M |  |  | NO | PR | 13-015 |  |  |

Notes:
- 13641025a: Entry Criteria: Ext Pred: BOD Tagger Bldg, BOD / Hall D
- 13641025ab: Entry Criteria: Ext Pred: BOD Tagger Bldg, BOD / Hall D
- 13641030a: Entry Criteria: Ext Pred: BOD Tagger Bldg, BOD / Hall D
- 13641060: Entry Criteria: Ext Pred: BOD Tagger Bldg, BOD / Tunnel Ext, New CMs installed
- 13641025: Entry Criteria: Ext Pred: BOD Tagger Bldg, BOD / Hall D / Steps: Install FSD Wire & Cable (MPS) FY12 (done)
- 13641025b: Entry Criteria: Ext Pred: BOD Tagger Bldg, BOD / Hall D / Steps: Install FSD Wire & Cable (MPS) FY13 (done)
- 13641030: Entry Criteria: Ext Pred: BOD Tagger Bldg, BOD / Hall D
- 13641095: Entry Criteria: Ext Pred: BOD Tagger Bldg, BOD / Tunnel Ext
- 23641020: Steps: Characterization (done); Integrated Test (done) / BOE NOTES: Based on implementation of similar cards for the South Linac RF C-100 systems.
- 23641040: Steps: Test EPICS SW (done); Finalize Screens (done)
- 23641040a: Steps: Test EPICS SW (done); Finalize Screens (done)
- 23641055: Steps: Test Power Supplies (done); Test BLM Assy on Bench; Burn-in; Integrated Test
- 23641055a: Steps: Test Power Supplies (done); Test BLM Assy on Bench; Burn-in; Integrated Test
- 23641085: Steps: Install Ion Chamber Electronics (done); Install BLM Cards (done); Install BLM HVPS
- 23641913LOE: BOE NOTES: Demands for management reports such as this were not in estimate.
- 23641025: Entry Criteria: Ext Pred: BOD Tagger Bldg, BOD / Hall D / Steps: Install NL Extension (done); Install Tagger FSD Fiber and Cable; Install Hall D FSD Fiber and Cable; Install FSD Tree Interconnect / BOE NOTES: Copper cable prices unstable. Still trending up.
- 23641025a: Entry Criteria: Ext Pred: BOD Tagger Bldg, BOD / Hall D / Steps: Install NL Extension (done); Install Tagger FSD Fiber and Cable; Install Hall D FSD Fiber and Cable; Install FSD Tree Interconnect / BOE NOTES: Copper cable prices unstable. Still trending up.
- 23641030a: Entry Criteria: Ext Pred: BOD Tagger Bldg, BOD / Hall D / Steps: Install/Test 1L23 FSD (done); Connect RF Inputs (done); Connect to FSD Tree (done); Test (done)
- 23641030aa: Entry Criteria: Ext Pred: BOD Tagger Bldg, BOD / Hall D / Steps: Install/Test 1L23 FSD (done); Connect RF Inputs (done); Connect to FSD Tree (done); Test (done)
- 23641100: Steps: Final Design - VME FSD (done); Final Design FSD Master; Build and Test VME FSD Cards (done); Re-work FSD Master; Build and Test FSD Master
- 23641065: Steps: Install Ion Chamber Electronics (done); Install BLM Cards; Install BLM HVPS
- 23641065a: Steps: Install Ion Chamber Electronics (done); Install BLM Cards; Install BLM HVPS
- 23641914LOE: BOE NOTES: Based on experience supporting 12GeV project. Addition is due to extending effort in to Fy14.
- 23641060: Entry Criteria: Ext Pred: BOD Tagger Bldg, BOD / Tunnel Ext, New CMs installed / Steps: Install NL-Hall D Xport BLM Cables (done); Install FSD Infrastructure (done); Terminate/QA Cables; As-Built Documentation
- 23641060a: Entry Criteria: Ext Pred: BOD Tagger Bldg, BOD / Tunnel Ext, New CMs installed / Steps: Install NL-Hall D Xport BLM Cables (done); Install FSD Infrastructure (done); Terminate/QA Cables; As-Built Documentation
- 23641087: Entry Criteria: Ext Pred: BOD Tagger Bldg, BOD / Tunnel Ext, New CMs installed / Steps: Install Tagger BLM Cables (done); Install Hall D BLM Cables (done); Terminate/QA Cables; As-Built Documentation / BOE NOTES: Based on similar installs in endstations and CEBAF accelerator.
- 23641087a: Entry Criteria: Ext Pred: BOD Tagger Bldg, BOD / Tunnel Ext, New CMs installed / Steps: Install Tagger BLM Cables (done); Install Hall D BLM Cables (done); Terminate/QA Cables; As-Built Documentation / BOE NOTES: Based on similar installs in endstations and CEBAF accelerator.
- 23641095: Entry Criteria: Ext Pred: BOD Tagger Bldg, BOD / Tunnel Ext / Steps: Finalize Documentation (done); Install BLM Heads; Install Ion Chambers; Install Ion Chamber HV Box / BOE NOTES: First installation of new VME based BLM card.
- 23641030: Entry Criteria: Ext Pred: BOD Tagger Bldg, BOD / Hall D / Steps: Install/Test FSD Master; Install/Test Tagger FSD HW; Install/Test Hall D FSD HW
- 23641090: Steps: Test Ion Chamber Electronics; Characterize Ion Chambers; Test IC Subsystem
- 23641090a: Steps: Test Ion Chamber Electronics; Characterize Ion Chambers; Test IC Subsystem
- 23641030b: Entry Criteria: Ext Pred: BOD Tagger Bldg, BOD / Hall D / Steps: Install/Test FSD Master; Install/Test Tagger FSD HW; Install/Test Hall D FSD HW
- 23641075: Steps: Test EPICS SW; Finalize Screens

| ID | WBS | Activity | Type | Duration | Start | Finish | Predecessors | Complete | Remaining | Planned start | Planned finish | Total float | Free float | Calendar | Resources | Cost | Actual cost | LOE Divider | LOE Multiplier | Calculated Remaining Total Cost | MONTHLY EV COST | RESP - Responsibility | STRT%COMP for CM EVM | FNSH%COMP for CM EVM | EVMS Reporting Codes | CAM RESPONSIBLE | CR 08-058 | LOE % Pre Calc | LOE % | OPC Allison | Remaining Material Cost Based on % Compl | Claimed Material Cost Based on % Complet | Initial Claimed Material Calc | Claimed Material Divider | CR 10-028 | CR 12-037 | Installation | CR 13-003 | ReBaseline Actuals Adjustment | Milestone Level | Original Activity ID Rebaseline | PRIOR MONTH EV COST | BOE Labor | BOE Adder | CR 13-015 | Post Rebaseline | Activities with Steps | CR 14-001 | BOE Procurement | BOE Expenses | CR 10-031 | CR 10-064 | CR 10-065 | CR 10-066 | CR 08-016 | CR 09-012 | CR 12-001 | MARCH!!! | CR 12-018 | CR 12-053 | CR 10-059 | CR 11-044 | CR 10-070 | CR 12-045 | New H Claim |
| --- | --- | --- | --- | --- | --- | --- | --- | --- | --- | --- | --- | --- | --- | --- | --- | --- | --- | --- | --- | --- | --- | --- | --- | --- | --- | --- | --- | --- | --- | --- | --- | --- | --- | --- | --- | --- | --- | --- | --- | --- | --- | --- | --- | --- | --- | --- | --- | --- | --- | --- | --- | --- | --- | --- | --- | --- | --- | --- | --- | --- | --- | --- | --- | --- | --- |
|  | 2 | **1.3.6.4.2 BELS** |  |  | 2009-01-02 | 2014-06-02 |  |  |  |  |  |  |  |  |  |  |  |  |  |  |  |  |  |  |  |  |  |  |  |  |  |  |  |  |  |  |  |  |  |  |  |  |  |  |  |  |  |  |  |  |  |  |  |  |  |  |  |  |  |  |  |  |  |  |  |
| 13642909LOE |  | FY09 Mngmnt & Elect Dsgn Supprt Effort for BELS |  | 189d | 2009-01-02 A | 2009-09-30 A | 13642909LOEX | 100% |  |  |  |  |  |  | SR STAFF [3.05 h]; ELEC DES [3.05 h] | 453.9 | 453.9 | 100 | 100 | 0 | 453.90017 | MAHONEY K | 1 | 1 | E | MIKE S | 08-058 |  |  |  |  |  |  |  |  |  |  |  |  |  |  |  |  |  |  |  |  |  |  |  |  |  |  |  |  |  |  |  |  |  |  |  |  |  |  |
| 13642910LOE |  | FY10 Mngmnt & Elect Dsgn Supprt Effort for BELS |  | 248d | 2009-10-01 A | 2010-09-30 A | 13642909LOE | 100% |  |  |  |  |  |  | ELEC DES [4 h]; SR STAFF [4 h] | 614.24 | 614.24 | 100 | 100 | 0 | 614.24 | MAHONEY K | 1 | 1 | E | MIKE S |  |  |  |  |  |  |  |  |  |  |  |  |  |  |  |  |  |  |  |  |  |  |  |  |  |  |  |  |  |  |  |  |  |  |  |  |  |  |  |
| 13642911LOE |  | FY11 Mngmnt & Elect Dsgn Supprt Effort for BELS |  | 248d | 2010-10-01 A | 2011-09-30 A | 13642910LOE | 100% |  |  |  |  |  |  | ELEC DES [36 h]; SR STAFF [36 h] | 5,704.56 | 5,704.56 | 100 | 100 | 0 | 5704.56 | MAHONEY K | 1 | 1 | E | MIKE S |  | 8.46774193 | 91.53225806 |  |  |  |  |  |  |  |  |  |  |  |  |  |  |  |  |  |  |  |  |  |  |  |  |  |  |  |  |  |  |  |  |  |  |  |  |
| 13642912LOE |  | FY12 Mngmnt & Elect Dsgn Supprt Effort for BELS |  | 247d | 2011-10-03 A | 2012-09-28 A | 13642911LOE | 100% |  |  |  |  |  |  | ELEC DES [36 h]; SR STAFF [36 h] | 5,886.36 | 5,886.36 | 100 | 100 | 0 | 5886.36 | MAHONEY K | 1 | 1 | E | MIKE S |  | 7.69230769 | 92.3076923 |  |  |  |  |  |  |  |  |  |  |  |  |  |  |  |  |  |  |  |  |  |  |  |  |  |  |  |  |  |  |  |  |  |  |  |  |
| 13642913LOE |  | FY13 Mngmnt & Elect Dsgn Supprt Effort for BELS |  | 248d | 2012-10-01 A | 2013-08-30 A | 13642912LOE | 100% |  | 2012-10-01 | 2013-09-30 |  |  |  | ELEC DES [33.09 h]; SR STAFF [33.09 h] | 5,583.79 | 5,583.79 | 100 | 100 | 1028.922048 | 5583.7884 | MAHONEY K | 1 | 1 | E | MIKE S |  | 8.06451612 | 91.93548387 | OPC A |  |  |  |  |  |  |  |  |  |  |  |  |  |  |  |  |  |  |  |  |  |  |  |  |  |  |  |  |  |  |  |  |  |  |  |
| 13642014 |  | Proc BELS Hardware |  | 42d | 2013-04-01 A | 2013-08-30 A | 9-120M FS+60d, 9-130M FS+100d, 121642070M, 121642170, 121642060 | 100% |  | 2013-05-01 | 2013-06-28 |  |  |  | ELEC ENG [40 h]; PROCUREMENT<$50K 60 | 28,746.13 | 2,912.4 |  |  | 14328.065 | 28656.13 | MAHONEY K | 1 | 1 | H | MIKE S |  |  |  | OPC A | 0 | 25833.73 | 2583373 | 100 | 10-028 | 12-037F |  |  |  |  |  |  |  |  |  |  |  |  |  |  |  |  |  |  |  |  |  |  |  |  |  |  |  |  |  |
| 13642005 |  | Develop/Install/Test BELS Software |  | 30d | 2013-08-26 A | 2013-08-30 A | 13642015, 13642020 FS-5d | 100% |  | 2013-11-20 | 2014-01-10 |  |  |  | ELEC ENG [80 h]; COMP SCIENT [80 h] | 11,600 | 11,241.6 |  |  | 11241.6 | 11241.6 | MAHONEY K | 1 | 1 | H | MIKE S |  |  |  | OPC A |  |  |  |  |  | 12-037 | Install |  |  |  |  |  |  |  |  |  |  |  |  |  |  |  |  |  |  |  |  |  |  |  |  |  |  |  |  |
| 13642015 |  | Test/QA BELS Compnts |  | 23d | 2013-08-30 A | 2013-08-30 A | 13642014 FS+35d, 13642019 FS-25d | 100% |  | 2013-11-19 | 2013-12-30 |  |  |  | ELEC TECH [160 h]; ELEC ENG [40 h] | 10,523.6 | 10,198.8 |  |  | 10198.8 | 10198.8 | MAHONEY K | 1 | 1 | H | MIKE S |  |  |  | OPC A |  |  |  |  | 10-028 | 12-037 |  |  |  |  |  |  |  |  |  |  |  |  |  |  |  |  |  |  |  |  |  |  |  |  |  |  |  |  |  |
| 13642019 |  | Proc Remaining BELS Hardware |  | 35d | 2013-08-30 A | 2013-08-30 A | 9-130M FS+193d | 100% |  | 2013-09-03 | 2013-10-21 |  |  |  | PROCUREMENT<$50K 60 | 3,000 |  |  |  | 3000 | 3000 | MAHONEY K | 1 | 1 | D | MIKE S |  |  |  |  | 0 | 3000 | 300000 | 100 | 10-028 | 12-037F |  | 13-003 |  |  |  |  |  |  |  |  |  |  |  |  |  |  |  |  |  |  |  |  |  |  |  |  |  |  |  |
| 13642020 |  | Install BELS Hardware |  | 42d | 2013-08-30 A | 2013-08-30 A | 16332030, 9-130M FS+45d, 13642015 FS-40d | 100% |  | 2013-10-25 | 2014-01-02 |  |  |  | ELEC TECH [240 h]; PLABOR; ELEC ENG [40 h] | 19,282.36 | 13,842 |  |  | 18841.56 | 18841.56 | MAHONEY K | 1 | 1 | H | MIKE S |  |  |  | OPC A |  |  |  |  |  | 12-037 | Install |  |  |  |  |  |  |  |  |  |  |  |  |  |  |  |  |  |  |  |  |  |  |  |  |  |  |  |  |
| 13642950 |  | Re-Baseline Actuals Adjustment |  | 1d | 2013-08-30 A | 2013-08-30 A |  | 100% |  | 2013-09-03 | 2013-09-03 |  |  |  | PROCUREMENT>$50K 69 NO ESCALATION | -79,687.15 |  |  |  |  |  |  |  |  |  |  |  |  |  |  |  |  |  | 100 |  |  |  |  | ADJ |  |  |  |  |  |  |  |  |  |  |  |  |  |  |  |  |  |  |  |  |  |  |  |  |  |  |
| 13642030M |  | BELS Sys Comp | milestone | 0d | 2013-08-30 A | 2013-08-30 A | 13642005, 13642020 | 100% |  | 2014-02-12 | 2014-02-12 |  |  |  |  |  |  |  |  |  | 0 | MAHONEY K | 1 | 1 | M | MIKE S |  |  |  | OPC A |  |  |  |  |  | 12-037 |  |  |  | 6 |  |  |  |  |  |  |  |  |  |  |  |  |  |  |  |  |  |  |  |  |  |  |  |  |  |
| 23642913LOE |  | FY13 Mngmnt & Elect Dsgn Supprt Effort for BELS |  | 20d | 2013-09-03 A | 2013-09-30 A | 9-130M FS+228d | 100% |  | 2013-10-01 | 2013-10-28 |  |  | 8/5 M-F w/JLAB Holidays ReBaseline | ELEC DES [2.9 h]; SR STAFF [2.9 h] | 504.89 | 489.29 | 100 | 100 |  | 0 | MAHONEY K | 1 | 1 | E | MIKE S |  |  |  |  |  |  |  |  |  |  |  |  |  |  | 23642913LOE | 489.288 | PE | NO | 13-015 | PR |  |  |  |  |  |  |  |  |  |  |  |  |  |  |  |  |  |  |  |
| 23642005 |  | Develop/Install/Test BELS Software |  | 50d | 2013-10-01 A | 2013-12-20 | 23642015 FS-60d, 23642020 FS-120d |  | 34d | 2013-11-14 | 2014-02-06 | 72d | 56d | 8/5 M-F w/JLAB Holidays ReBaseline | COMP SCIENT [72 h]; ELEC ENG [72 h] | 10,440 | 4,212.63 |  |  |  | 0 | MAHONEY K | 1 | 1 | S | MIKE S |  |  |  |  |  |  |  |  |  | 12-037 |  |  |  |  | 23642005 |  | PE | NO | 13-015 | PR | ST | 14-001 |  |  |  |  |  |  |  |  |  |  |  |  |  |  |  |  |  |
| 23642014 |  | Proc BELS Hardware |  | 31d | 2013-10-01 A | 2013-11-18 | 9-140M |  | 12d | 2013-11-01 | 2013-12-17 | 21d | 5d | 8/5 M-F w/JLAB Holidays ReBaseline | PROCUREMENT<$50K 60; ELEC ENG [16 h] | 11,865.21 | 789.94 |  |  |  | 0 | MAHONEY K | 1 | 1 | S | MIKE S |  |  |  |  | 10663.13 | 0 | 0 | 100 | 10-028 | 12-037F |  |  |  |  | 23642014 |  | PE | NO | 13-015 | PR | ST | 14-001 | CP |  |  |  |  |  |  |  |  |  |  |  |  |  |  |  |  |
| 23642914LOE |  | FY14 Mngmnt & Elect Dsgn Supprt Effort for BELS |  | 163d | 2013-10-01 A | 2014-06-02 | 23642913LOE | 14% | 140d | 2013-11-01 | 2014-07-03 | 142d |  | 8/5 M-F w/JLAB Holidays ReBaseline | ELEC DES [21.63 h]; SR STAFF [21.63 h] | 3,765.78 | 531.37 | 100 | 100 |  | 531.3519813 | MAHONEY K | 1 | 1 | E | MIKE S |  | 85.88957055 | 14.11042944 |  |  |  |  |  |  |  |  |  |  |  | 23642914LOE |  | PE | NO | 13-015 | PR |  | 14-001 |  |  |  |  |  |  |  |  |  |  |  |  |  |  |  |  |  |
| 23642015 |  | Test/QA BELS Compnts |  | 42d | 2013-11-11 | 2014-01-22 | 23642014 FS-11d, 23642019 FS-30d |  |  |  |  | 16d | 0d | 8/5 M-F w/JLAB Holidays ReBaseline | ELEC ENG [40 h]; ELEC TECH [160 h] | 10,523.6 |  |  |  |  | 0 | MAHONEY K | 1 | 1 | S | MIKE S |  |  |  |  |  |  |  |  | 10-028 | 12-037 |  |  |  |  | 23642015 |  | PE | NO | 13-015 | PR | ST | 14-001 |  |  |  |  |  |  |  |  |  |  |  |  |  |  |  |  |  |
| 23642019 |  | Proc Remaining BELS Hardware |  | 29d | 2013-11-12 | 2014-01-03 | 9-140M FS+30d |  |  |  |  | 16d | 0d | 8/5 M-F w/JLAB Holidays ReBaseline | PROCUREMENT<$50K 60 | 3,095.7 |  |  |  |  | 0 | MAHONEY K | 1 | 1 | S | MIKE S |  |  |  |  | 3095.7 | 0 | 0 | 100 | 10-028 | 12-037F |  | 13-003 |  |  | 23642019 |  | PE | NO | 13-015 | PR | ST | 14-001 | CP |  |  |  |  |  |  |  |  |  |  |  |  |  |  |  |  |
| 23642020 |  | Install BELS Hardware |  | 22d | 2014-02-20 | 2014-03-21 | 23642015 FS+20d |  |  |  |  | 16d | 0d | 8/5 M-F w/JLAB Holidays ReBaseline | PLABOR; ELEC ENG [56 h]; ELEC TECH [216 h] | 19,516.62 |  |  |  |  | 0 | MAHONEY K | 1 | 1 | S | MIKE S |  |  |  |  |  |  |  |  |  | 12-037 |  |  |  |  | 23642020 |  | PE | NO | 13-015 | PR | ST | 14-001 |  | PE |  |  |  |  |  |  |  |  |  |  |  |  |  |  |  |
| 23642030M |  | BELS Sys Comp | milestone | 0d | 2014-03-21 | 2014-03-21 | 23642020, 23642005 |  |  |  |  | 16d | 0d | 8/5 M-F w/JLAB Holidays ReBaseline |  |  |  |  |  |  | 0 | MAHONEY K | 1 | 1 | M | MIKE S |  |  |  |  |  |  |  |  |  | 12-037 |  |  |  | 6 | 23642030M |  |  | NO | 13-015 | PR |  |  |  |  |  |  |  |  |  |  |  |  |  |  |  |  |  |  |  |
|  | 3 | **1.3.6.4.3 PSS** |  |  | 2009-01-02 | 2014-06-02 |  |  |  |  |  |  |  |  |  |  |  |  |  |  |  |  |  |  |  |  |  |  |  |  |  |  |  |  |  |  |  |  |  |  |  |  |  |  |  |  |  |  |  |  |  |  |  |  |  |  |  |  |  |  |  |  |  |  |  |
| 13643909LOE |  | FY09 Mngmnt & Supprt Effort for PSS |  | 189d | 2009-01-02 A | 2009-09-30 A | 13643909LOEX | 100% |  |  |  |  |  |  | OFFICE [18.29 h]; ELEC ENG [9.15 h]; SR STAFF [6.1 h]; ELEC DES [18.29 h] | 2,531.16 | 2,531.16 | 100 | 100 | 0 | 2531.176485 | MAHONEY K | 1 | 1 | E | MIKE S | 08-058 |  |  |  |  |  |  |  |  |  |  |  |  |  |  |  |  |  |  |  |  |  |  |  |  |  |  |  |  |  |  |  |  |  |  |  |  |  |  |
| 13643910LOE |  | FY10 Mngmnt & Supprt Effort for PSS |  | 248d | 2009-10-01 A | 2010-09-30 A | 13643909LOE | 100% |  |  |  |  |  |  | ELEC ENG [12 h]; OFFICE [24 h]; SR STAFF [8 h]; ELEC DES [24 h] | 3,426.2 | 3,426.2 | 100 | 100 | 0 | 3426.199102 | MAHONEY K | 1 | 1 | E | MIKE S |  |  |  |  |  |  |  |  |  |  |  |  |  |  |  |  |  |  |  |  |  |  |  |  |  |  |  |  |  |  |  |  |  |  |  |  |  |  |  |
| 13643040a |  | Proc Local Cable, Conduit, Infrastructure for RF Installation (PSS) |  | 42d | 2010-05-03 A | 2010-06-30 A | 9-110M FS-100d | 100% |  |  |  |  |  |  | ELEC ENG [40 h]; PROCUREMENT<$50K 60 | 7,010.58 | 2,650.8 |  |  | 0 | 7094.98 | MAHONEY K | 1 | 1 | D | MIKE S |  |  |  |  | 0 | 4359.78 | 435978 | 100 |  |  |  |  |  |  |  |  |  |  |  |  |  |  |  |  | 10-031 | 10-064 | 10-065 | 10-066 |  |  |  |  |  |  |  |  |  |  |  |
| 13643045a |  | Install Linac Cable Conduit, Infrastructure for RF Installation (PSS) |  | 17d | 2010-07-01 A | 2010-07-26 A | 13643040a FS+80d | 100% |  |  |  |  |  |  | ELEC TECH [180 h]; ELEC DES [60 h] | 10,307.4 | 10,307.4 |  |  | 0 | 10635.6 | MAHONEY K | 1 | 1 | H | MIKE S |  |  |  |  |  |  |  |  |  |  |  |  |  |  |  |  |  |  |  |  |  |  |  |  | 10-031 | 10-064 | 10-065 | 10-066 |  |  |  |  |  |  |  |  |  |  |  |
| 13643911LOE |  | FY11 Mngmnt & Supprt Effort for PSS |  | 276d | 2010-08-23 A | 2011-09-30 A | 13643910LOE FS-20d | 100% |  |  |  |  |  |  | ELEC DES [396 h]; OFFICE [24 h]; ELEC ENG [196 h]; SR STAFF [88 h] | 42,952.67 | 42,952.67 | 100 | 100 | 0 | 43087.639665 | MAHONEY K | 1 | 1 | S | MIKE S |  |  |  |  |  |  |  |  |  |  |  |  |  |  |  |  |  |  |  |  | ST |  |  |  |  |  |  |  |  |  |  |  |  |  |  |  |  |  |  |
| 13643040 |  | Proc Local Cable, Conduit, Infrastructure (PSS) Labor FY11 (FY12 @ 13643040b) |  | 584d | 2010-09-01 A | 2013-08-30 A | 9-110M, 121643140 | 100% |  | 2010-09-01 | 2013-01-14 |  |  |  | ELEC ENG [99.43 h] | 6,934.44 | 6,999.83 |  |  | 679.90234 | 6799.0234 | MAHONEY K | 1 | 1 | D | MIKE S |  |  |  |  |  |  |  |  |  |  |  |  |  |  |  |  |  |  |  |  |  |  |  |  | 10-031 |  |  |  | 08-016 | 09-012 | 12-001 | XX |  |  |  |  |  |  |  |
| 13643040b |  | Proc Local Cable, Conduit, Infrastructure (PSS) Labor FY12 (FY11 @ 13643040) |  | 547d | 2010-09-01 A | 2012-11-12 A | 13643040 FS-95d | 100% |  |  |  |  |  |  | ELEC ENG [20.57 h] | 1,430.32 | 1,430.32 |  |  | 0 | 1451.4192 | MAHONEY K | 1 | 1 | D | MIKE S |  |  |  |  |  |  |  |  |  |  |  |  |  |  |  |  |  |  |  |  |  |  |  |  | 10-031 |  |  |  | 08-016 | 09-012 | 12-001 |  |  |  |  |  |  |  |  |
| 13643040c |  | Proc Local Cable, Conduit, Infrastructure (PSS) Labor Procurement |  | 547d | 2010-09-01 A | 2012-11-12 A | 121643140, 9-110M | 100% |  |  |  |  |  |  | PROCUREMENT<$50K 60 NO ESCALATION FY12 | 30,743.7 |  |  |  | 0 | 30743.7 | MAHONEY K | 1 | 1 | D | MIKE S |  |  |  |  | 0 | 30743.7 | 3074370 | 100 |  |  |  |  |  |  |  |  |  |  |  |  |  |  |  |  | 10-031 |  |  |  | 08-016 | 09-012 | 12-001 |  |  |  |  |  |  |  |  |
| 13643030 |  | Proc Custom Compnts (Run/Safe, Interface Chassis) (PSS) Labor FY11(FY12 @ 13643030b) |  | 358d | 2010-10-01 A | 2012-03-19 A | 121643140, 9-110M | 100% |  | 2010-10-01 | 2012-03-16 |  |  |  | ELEC ENG [7.31 h]; ELEC TECH [14.62 h]; PLABOR | 1,396.75 | 1,154.84 |  |  | 0 | 1385.7452 | MAHONEY K | 1 | 1 | D | MIKE S |  |  |  |  |  |  |  |  |  |  |  |  |  |  |  |  |  |  |  |  |  |  |  |  | 10-031 |  |  |  | 08-016 | 09-012 | 12-001 |  | 12-018F |  |  |  |  |  |  |
| 13643030a |  | Proc Custom Compnts (Run/Safe, Interface Chassis) for RF Installation (PSS) |  | 116d | 2010-10-01 A | 2011-03-25 A | 9-110M | 100% |  |  |  |  |  |  | PLABOR; PROCUREMENT<$50K 60; ELEC TECH [60 h]; ELEC ENG [20 h] | 30,391.72 | 3,933.8 |  |  | 0 | 30391.72 | MAHONEY K | 1 | 1 | D | MIKE S |  |  |  |  | 0 | 10319 | 1031900 | 100 |  |  |  |  |  |  |  |  |  |  |  |  |  |  |  |  | 10-031 |  |  |  |  |  |  |  | 12-018F |  |  |  |  |  |  |
| 13643030b |  | Proc Custom Compnts (Run/Safe, Interface Chassis) (PSS) Labor FY12 (FY11 @ 13643030) |  | 359d | 2010-10-01 A | 2012-03-19 A | 13643030 FS-245d | 100% |  |  |  |  |  |  | PLABOR; ELEC ENG [7.13 h]; ELEC TECH [14.26 h] | 1,370.66 | 1,108.26 |  |  | 0 | 1394.78634 | MAHONEY K | 1 | 1 | D | MIKE S |  |  |  |  |  |  |  |  |  |  |  |  |  |  |  |  |  |  |  |  |  |  |  |  | 10-031 |  |  |  | 08-016 | 09-012 | 12-001 |  | 12-018F |  |  |  |  |  |  |
| 13643030c |  | Proc Custom Compnts (Run/Safe, Interface Chassis) (PSS) Procurement |  | 359d | 2010-10-01 A | 2012-03-19 A | 121643140, 9-110M | 100% |  |  |  |  |  |  | PROCUREMENT<$50K 60 NO ESCALATION FY12 | 8,400.65 |  |  |  | 0 | 8400.65 | MAHONEY K | 1 | 1 | D | MIKE S |  |  |  |  | 0 | 8400.65 | 840065 | 100 |  |  |  |  |  |  |  |  |  |  |  |  |  |  |  |  | 10-031 |  |  |  | 08-016 | 09-012 | 12-001 |  | 12-018F |  |  |  |  |  |  |
| 13643035 |  | Test/QA Custom Compnts (PSS) FY11 (FY12 @ 13643035b) |  | 357.07d | 2010-11-01 A | 2012-04-16 A | 13643030b FS-460d, 13643030c FS-460d | 100% |  |  |  |  |  |  | ELEC TECH [106.78 h] | 4,619.88 | 4,619.88 |  |  | 0 | 4566.9806 | MAHONEY K | 1 | 1 | U | MIKE S |  |  |  |  |  |  |  |  |  |  |  |  |  |  |  |  |  |  |  |  |  |  |  |  | 10-031 |  |  |  |  |  | 12-001 |  | 12-018F |  |  |  |  |  |  |
| 13643035b |  | Test/QA Custom Compnts (PSS) FY12 (FY11 @ 13643035) |  | 542d | 2010-11-01 A | 2013-02-13 A | 13643035 FS-275d | 100% |  | 2010-11-01 | 2013-01-14 |  |  |  | ELEC TECH [120.98 h] | 5,291.34 | 5,299.36 |  |  | 0 | 5338.8474 | MAHONEY K | 1 | 1 | U | MIKE S |  |  |  |  |  |  |  |  |  |  |  |  |  |  |  |  |  |  |  |  |  |  |  |  | 10-031 |  |  |  |  |  | 12-001 | XX | 12-018F | 12-053 |  |  |  |  |  |
| 13643035ba |  | Test/QA Custom Compnts (PSS) FY13 |  | 542d | 2010-11-01 A | 2013-02-14 A | 13643035b FS-50d | 100% |  | 2010-11-01 | 2013-01-14 |  |  |  | ELEC TECH [12.24 h] | 535.34 | 536.21 |  |  | 0 | 557.4096 | MAHONEY K | 1 | 1 | U | MIKE S |  |  |  |  |  |  |  |  |  |  |  |  |  |  |  |  |  |  |  |  |  |  |  |  | 10-031 |  |  |  |  |  | 12-001 | XX | 12-018F | 12-053 |  |  |  |  |  |
| 13643160 |  | Create & Simulate PSS Logic Programs |  | 543d | 2010-11-01 A | 2013-08-30 A | 9-110M | 100% |  | 2010-11-01 | 2013-01-15 |  |  |  | ELEC ENG [320 h] | 22,379.06 | 22,587.47 |  |  | 10940.8 | 21881.6 | MAHONEY K | 1 | 1 | H | MIKE S |  |  |  |  |  |  |  |  |  | 12-037F |  |  |  |  |  |  |  |  |  |  |  |  |  |  |  |  |  |  |  |  |  | XX |  |  |  |  |  |  |  |
| 13643020a |  | Proc PLC Systems for RF Installation (PSS) |  | 45d | 2010-11-15 A | 2011-01-27 A | 9-110M FS+21d | 100% |  |  |  |  |  |  | ELEC ENG [40 h]; PROCUREMENT<$50K 60 | 40,502.74 | 2,735.2 |  |  | 0 | 40502.74 | MAHONEY K | 1 | 1 | D | MIKE S |  |  |  |  | 0 | 37767.54 | 3776754 | 100 |  | 12-037F |  |  |  |  |  |  |  |  |  |  |  |  |  |  | 10-031 | 10-064 |  |  |  |  |  |  |  |  |  |  |  |  |  |
| 13643035a |  | Test/QA Custom Compnts for RF Installation (PSS) FY11 |  | 27d | 2011-01-04 A | 2011-02-10 A | 13643030a FS-20d | 100% |  |  |  |  |  |  | ELEC TECH [31.43 h] | 1,344.26 | 1,344.26 |  |  | 0 | 1344.2611 | MAHONEY K | 1 | 1 | S | MIKE S |  |  |  |  |  |  |  |  |  |  |  |  |  |  |  |  |  |  |  |  | ST |  |  |  | 10-031 |  |  |  |  |  | 12-001 |  | 12-018F |  |  |  |  |  |  |
| 13643035ab |  | Test/QA Custom Compnts for RF Installation (PSS) FY12 |  | 27d | 2011-01-04 A | 2011-02-10 A | 13643035a | 100% |  |  |  |  |  |  | ELEC TECH [44.11 h] | 1,886.58 | 1,886.58 |  |  | 0 | 1946.5743 | MAHONEY K | 1 | 1 | S | MIKE S |  |  |  |  |  |  |  |  |  |  |  |  |  |  |  |  |  |  |  |  | ST |  |  |  | 10-031 |  |  |  |  |  | 12-001 |  | 12-018F | 12-053 |  |  |  |  |  |
| 13643035abb |  | Test/QA Custom Compnts for RF Installation (PSS) FY13 |  | 27d | 2011-01-04 A | 2011-02-10 A | 13643035ab | 100% |  |  |  |  |  |  | ELEC TECH [4.46 h] | 190.75 | 190.75 |  |  | 0 | 203.1084 | MAHONEY K | 1 | 1 | S | MIKE S |  |  |  |  |  |  |  |  |  |  |  |  |  |  |  |  |  |  |  |  | ST |  |  |  | 10-031 |  |  |  |  |  | 12-001 |  | 12-018F | 12-053 |  |  |  |  |  |
| 13643045 |  | Install Linac Cable Conduit, Infrastructure (PSS) FY12 |  | 443d | 2011-03-25 A | 2013-05-13 A | 13643040c FS-200d, 16332030 FS-200d, 16331032, 13643040b FS-200d, 3A-07M FS-200d, 16331030 | 100% |  | 2011-03-25 | 2013-01-07 |  |  |  | SKLLD TRADE [369.1 h]; ELEC TECH [567.85 h]; ELEC DES [56.79 h]; PLABOR | 121,215.37 | 40,328.98 |  |  | 0 | 121404.9284 | MAHONEY K | 1 | 1 | S | MIKE S |  |  |  | OPC A |  |  |  |  |  |  |  |  |  |  |  |  |  |  |  |  | ST |  |  |  | 10-031 |  |  |  |  |  |  | XX | 12-018F | 12-053 | 10-059 | 11-044 |  |  |  |
| 13643045b |  | Install Linac Cable Conduit, Infrastructure (PSS) FY13 |  | 443d | 2011-03-25 A | 2013-05-13 A | 13643045 FS-50d | 100% |  | 2011-03-25 | 2013-01-07 |  |  |  | ELEC TECH [77.43 h]; ELEC DES [7.74 h]; SKLLD TRADE [50.33 h]; PLABOR | 16,881.83 | 5,499 |  |  | 0 | 17083.1726 | MAHONEY K | 1 | 1 | S | MIKE S |  |  |  |  |  |  |  |  |  |  |  |  |  |  |  |  |  |  |  |  | ST |  |  |  | 10-031 |  |  |  |  |  |  | XX | 12-018F | 12-053 | 10-059 | 11-044 |  |  |  |
| 13643050 |  | Proc COTS Compnts (Access Control, Video,etc) (PSS) Labor FY11 |  | 438d | 2011-03-25 A | 2012-12-17 A | 121643170, 121643140, 9-110M FS+60d | 100% |  | 2011-03-25 | 2012-12-21 |  |  |  | ELEC ENG [245.55 h]; ELEC TECH [184.16 h] | 25,321.93 | 25,313.25 |  |  | 0 | 24667.2322 | MAHONEY K | 1 | 1 | D | MIKE S |  |  |  |  |  |  |  |  |  |  |  |  |  |  |  |  |  |  |  |  |  |  |  |  |  |  |  |  | 08-016 | 09-012 | 12-001 |  | 12-018F |  |  |  |  |  |  |
| 13643050a |  | Proc COTS Compnts (Access Control, Video,etc) (PSS) Labor FY12 |  | 438d | 2011-03-25 A | 2012-12-17 A | 13643050 FS-145d | 100% |  | 2011-03-25 | 2012-12-21 |  |  |  | ELEC ENG [74.45 h]; ELEC TECH [55.84 h] | 7,677.67 | 7,675.04 |  |  | 0 | 7717.4112 | MAHONEY K | 1 | 1 | D | MIKE S |  |  |  |  |  |  |  |  |  |  |  |  |  |  |  |  |  |  |  |  |  |  |  |  |  |  |  |  | 08-016 | 09-012 | 12-001 |  | 12-018F |  |  |  |  |  |  |
| 13643050b |  | Proc COTS Compnts (Access Control, Video,etc) (PSS) Procurement |  | 438d | 2011-03-25 A | 2012-12-17 A | 121643170, 9-110M FS+60d, 121643140 | 100% |  | 2011-03-25 | 2012-12-21 |  |  |  | PROCUREMENT<$50K 60 NO ESCALATION FY12 | 101,795.84 |  |  |  | 0 | 101795.84 | MAHONEY K | 1 | 1 | D | MIKE S |  |  |  |  | 0 | 101795.84 | 10179584 | 100 |  |  |  |  |  |  |  |  |  |  |  |  |  |  |  |  |  |  |  |  | 08-016 | 09-012 | 12-001 |  | 12-018F |  |  |  |  |  |  |
| 13643110 |  | Proc PSS Beam Current Monitor Compnts |  | 322d | 2011-03-25 A | 2012-07-09 A | 121643170, 121643140 | 100% |  |  |  |  |  |  | ELEC ENG [80 h]; PROCUREMENT<$50K 60 | 20,069.15 | 5,572.77 |  |  | 0 | 20141.18 | MAHONEY K | 1 | 1 | D | MIKE S |  |  |  |  | 0 | 14496.38 | 1449638 | 100 |  | 12-037F |  |  |  |  |  |  |  |  |  |  |  |  |  |  |  |  |  |  |  |  |  |  |  |  |  |  |  |  |  |
| 13643025a |  | Test/QA PLC Systems for RF Installation (PSS) |  | 16d | 2011-05-01 A | 2011-05-23 A | 13643020a | 100% |  | 2011-05-02 | 2011-05-23 |  |  |  | ELEC ENG [24 h]; ELEC TECH [16 h] | 2,325.44 | 2,325.44 |  |  | 0 | 2325.44 | MAHONEY K | 1 | 1 | H | MIKE S |  |  |  |  |  |  |  |  |  | 12-037F |  |  |  |  |  |  |  |  |  |  |  |  |  |  | 10-031 | 10-064 |  |  |  |  |  |  |  |  |  |  |  |  |  |
| 13643075 |  | Install RF, Mag Interfaces (PSS) |  | 291d | 2011-05-16 A | 2012-07-16 A | 16111025, 13224020 FS-20d, 16332030 FS-300d | 100% |  |  |  |  |  |  | ELEC ENG [120 h]; ELEC TECH [120 h] | 13,621.2 | 13,621.2 |  |  | 0 | 13762.8 | MAHONEY K | 1 | 1 | H | MIKE S |  |  |  |  |  |  |  |  |  | 12-037F | Install |  |  |  |  |  |  |  |  |  |  |  |  |  |  |  |  | 10-066 |  |  |  |  |  |  |  | 11-044 | 10-070 |  |  |
| 13643080 |  | Upgrade Existing PLC Sys in Linacs (PSS) |  | 416d | 2011-05-16 A | 2012-12-17 A | 13643025 FS-235d, 13643025a | 100% |  | 2011-05-16 | 2013-01-18 |  |  |  | ELEC TECH [160 h]; ELEC ENG [160 h] | 18,319.69 | 18,291.82 |  |  | 0 | 18350.4 | MAHONEY K | 1 | 1 | H | MIKE S |  |  |  |  |  |  |  |  |  | 12-037F |  |  |  |  |  |  |  |  |  |  |  |  |  |  | 10-031 | 10-064 |  |  |  |  |  |  |  |  |  |  |  |  |  |
| 13643165a |  | Install & Test PSS Logic Programs for Linac RF Upgrade |  | 38d | 2011-06-15 A | 2011-08-08 A | 13643045a FS+246d | 100% |  |  |  |  |  |  | ELEC TECH [20 h]; ELEC ENG [20 h] | 2,223 | 2,223 |  |  | 0 | 2223 | MAHONEY K | 1 | 1 | H | MIKE S |  |  |  |  |  |  |  |  |  |  |  |  |  |  |  |  |  |  |  |  |  |  |  |  | 10-031 | 10-064 | 10-065 | 10-066 |  |  |  |  |  |  |  |  |  |  |  |
| 13643912LOE |  | FY12 Mngmnt & Supprt Effort for PSS |  | 247d | 2011-10-03 A | 2012-09-28 A | 13643911LOE | 100% |  |  |  |  |  |  | ELEC ENG [196 h]; ELEC DES [396 h]; OFFICE [24 h]; SR STAFF [88 h] | 44,460.92 | 44,460.92 | 100 | 100 | 0 | 44460.92 | MAHONEY K | 1 | 1 | E | MIKE S |  | 7.69230769 | 92.3076923 |  |  |  |  |  |  |  |  |  |  |  |  |  |  |  |  |  |  |  |  |  |  |  |  |  |  |  |  |  |  |  |  |  |  |  |  |
| 13643085 |  | Fab & Install Tagger Bldg. Racks (PSS) |  | 161d | 2012-01-03 A | 2012-08-20 A | 16332030 FS-250d | 100% |  |  |  |  |  |  | ELEC ENG [40 h]; PLABOR; ELEC TECH [80 h] | 15,739.76 | 6,352.8 |  |  | 0 | 15739.76 | MAHONEY K | 1 | 1 | H | MIKE S |  |  |  |  |  |  |  |  |  |  | Install |  |  |  |  |  |  |  |  |  |  |  |  |  |  |  |  |  |  |  |  |  |  |  | 10-059 | 11-044 |  |  |  |
| 13643090 |  | Fab & Install H-D Racks PSS |  | 161d | 2012-01-03 A | 2012-08-20 A | 16332030 FS-250d | 100% |  |  |  |  |  |  | ELEC ENG [40 h]; ELEC TECH [80 h]; PLABOR | 15,725.71 | 6,352.8 |  |  | 0 | 15725.71 | MAHONEY K | 1 | 1 | H | MIKE S |  |  |  |  |  |  |  |  |  |  | Install |  |  |  |  |  |  |  |  |  |  |  |  |  |  |  |  |  |  |  |  |  |  |  | 10-059 | 11-044 |  |  |  |
| 13643014 |  | Let Endstation PSS Cable Plant Contract |  | 33d | 2012-02-01 A | 2012-03-19 A | 121643170, 16332030 FS-60d, 9-120M FS+60d | 100% |  |  |  |  |  |  | ELEC ENG [144 h]; PROCUREMENT<$50K 60 | 31,290.96 | 10,160.64 |  |  | 0 | 31290.96 | MAHONEY K | 1 | 1 | H | MIKE S |  |  |  |  | 0 | 21130.32 | 2113032 | 100 |  | 12-037F |  |  |  |  |  |  |  |  |  |  |  |  |  |  |  |  |  |  |  |  |  |  | 12-018F |  |  |  |  |  |  |
| 13643055 |  | Test/QA COTS Compnts (PSS) |  | 214d | 2012-03-02 A | 2013-03-11 A | 13643050b FS-80d, 13643050a FS-80d | 100% |  | 2012-03-02 | 2013-01-10 |  |  |  | ELEC TECH [400 h]; ELEC ENG [40 h] | 20,676.1 | 20,747.33 |  |  | 0 | 20474.4 | MAHONEY K | 1 | 1 | H | MIKE S |  |  |  |  |  |  |  |  |  |  |  |  |  |  |  |  |  |  |  |  |  |  |  |  |  |  |  |  |  |  |  |  | 12-018F |  |  |  |  |  |  |
| 13643145 |  | Install & Test Access Control Sys (PSS) |  | 366d | 2012-03-15 A | 2013-08-30 A | 16333030, 13643035ab, 13643035ba FS-165d, 13643045b FS-165d, 16331032, 16331030, 13643055 FS-125d, 13643210 FS-180d, 13643035abb, 16332030 | 100% |  | 2012-03-15 | 2013-08-29 |  |  |  | ELEC TECH [400 h]; ELEC ENG [240 h] | 35,271.12 | 35,272.27 |  |  | 17845.2 | 35690.4 | MAHONEY K | 1 | 1 | H | MIKE S |  |  |  | OPC A |  |  |  |  |  | 12-037 | Install |  |  |  |  |  |  |  |  |  |  |  |  |  |  |  |  |  |  |  |  |  | 12-018F |  |  |  |  |  |  |
| 13643015 |  | PSS Cable Plant Installtn (Contract Oversight) |  | 31d | 2012-04-02 A | 2012-05-14 A | 13643014, 16331030, 16331032, 16332030 | 100% |  |  |  |  |  |  | ELEC ENG [80 h]; ELEC TECH [40 h] | 7,410 | 7,410 |  |  | 0 | 7410 | MAHONEY K | 1 | 1 | H | MIKE S |  |  |  |  |  |  |  |  |  | 12-037F | Install |  |  |  |  |  |  |  |  |  |  |  |  |  |  |  |  |  |  |  |  |  | 12-018F |  |  |  |  |  |  |
| 13643210 |  | Cable Plant - Field Termination (PSS) |  | 156d | 2012-06-01 A | 2013-08-30 A | 13643015 | 100% |  | 2012-06-01 | 2013-01-18 |  |  |  | ELEC ENG [40 h]; ELEC TECH [80 h]; PLABOR | 24,132.57 | 6,501 |  |  | 12120.885 | 24241.77 | MAHONEY K | 1 | 1 | H | MIKE S |  |  |  | OPC A |  |  |  |  |  | 12-037 |  |  |  |  |  |  |  |  |  |  |  |  |  |  |  |  |  |  |  |  |  | XX | 12-018F |  |  |  |  |  |  |
| 13643115 |  | Test/QA PSS Beam Current Monitor Compnts |  | 133d | 2012-06-11 A | 2013-08-30 A | 13643110 FS-15d | 100% |  | 2012-06-11 | 2012-12-17 |  |  |  | ELEC ENG [80 h]; ELEC TECH [40 h] | 7,505.98 | 7,585.57 |  |  | 3705 | 7410 | MAHONEY K | 1 | 1 | H | MIKE S |  |  |  |  |  |  |  |  |  | 12-037F |  |  |  |  |  |  |  |  |  |  |  |  |  |  |  |  |  |  |  |  |  |  |  |  |  |  |  |  |  |
| 13643125 |  | Proc ODH Monitoring Sys (PSS) |  | 31d | 2012-07-09 A | 2012-08-20 A | 121643140, 121643170, 9-120M FS+190d | 100% |  |  |  |  |  |  | ELEC ENG [40 h] | 2,822.4 | 2,822.4 |  |  | 0 | 2822.4 | MAHONEY K | 1 | 1 | H | MIKE S |  |  |  |  |  |  |  |  |  | 12-037F |  |  |  |  |  |  |  |  |  |  |  |  |  |  |  |  |  |  |  |  |  |  |  |  |  |  |  |  |  |
| 13643215 |  | Tagger ODH Management Oversight FY12 |  | 121d | 2012-08-01 A | 2013-03-11 A | 9-120M FS+205d | 100% |  | 2012-08-01 | 2013-01-30 |  |  |  | ELEC ENG [1.09 h]; SCIENTIST [6.55 h] | 550.63 | 551.78 |  |  | 0 | 539.4059 | MAHONEY K | 1 | 1 | H | MIKE S |  |  |  |  |  |  |  |  |  | 12-037 |  |  |  |  |  |  |  |  |  |  |  |  |  |  |  |  |  |  |  |  |  | XX | 12-018F | 12-053 |  |  |  | 12-045 |  |
| 13643215a |  | Tagger ODH Management Oversight FY13 |  | 121d | 2012-08-01 A | 2013-03-11 A | 13643215 FS-75d | 100% |  | 2012-08-01 | 2013-01-30 |  |  |  | ELEC ENG [0.91 h]; SCIENTIST [5.45 h] | 458.38 | 459.29 |  |  | 0 | 463.3441 | MAHONEY K | 1 | 1 | H | MIKE S |  |  |  |  |  |  |  |  |  | 12-037 |  |  |  |  |  |  |  |  |  |  |  |  |  |  |  |  |  |  |  |  |  | XX | 12-018F | 12-053 |  |  |  | 12-045 |  |
| 13643220 |  | Change Control Process |  | 8d | 2012-08-01 A | 2012-08-10 A | 9-120M FS+205d | 100% |  |  |  |  |  |  | ELEC ENG [4 h]; SCIENTIST [4 h] | 564.68 | 564.68 |  |  | 0 | 564.68 | MAHONEY K | 1 | 1 | H | MIKE S |  |  |  |  |  |  |  |  |  | 12-037 |  |  |  |  |  |  |  |  |  |  |  |  |  |  |  |  |  |  |  |  |  |  | 12-018F |  |  |  |  | 12-045 |  |
| 13643240 |  | 5 C Line ODH Procurements |  | 39d | 2012-08-01 A | 2012-09-26 A | 13643235 FS-7d | 100% |  | 2012-08-01 | 2012-09-25 |  |  |  | ELEC ENG [5 h]; ELEC TECH [5 h]; PROCUREMENT<$50K 60 | 7,573.45 | 573.45 |  |  | 0 | 7573.45 | MAHONEY K | 1 | 1 | H | MIKE S |  |  |  |  | 0 | 7000 | 700000 | 100 |  | 12-037 |  |  |  |  |  |  |  |  |  |  |  |  |  |  |  |  |  |  |  |  |  |  | 12-018F |  |  |  |  | 12-045 | Aug 12 |
| 13643255 |  | Hall D ODH Procurements |  | 32d | 2012-08-01 A | 2012-09-17 A | 13643235 FS-7d | 100% |  | 2012-08-01 | 2012-09-14 |  |  |  | ELEC TECH [5 h]; ELEC ENG [5 h]; PROCUREMENT<$50K 60 | 18,573.45 | 573.45 |  |  | 0 | 18573.45 | MAHONEY K | 1 | 1 | D | MIKE S |  |  |  |  | 0 | 18000 | 1800000 | 100 |  | 12-037 |  |  |  |  |  |  |  |  |  |  |  |  |  |  |  |  |  |  |  |  |  |  | 12-018F |  |  |  |  | 12-045 |  |
| 13643280 |  | EPICS Interface Development FY12 |  | 111d | 2012-08-15 A | 2013-08-30 A | 9-120M | 100% |  | 2012-08-15 | 2013-01-30 |  |  |  | ELEC ENG [2.27 h]; COMP SCIENT [11.34 h] | 921.17 | 930.8 |  |  | 452.151 | 904.302 | MAHONEY K | 1 | 1 | H | MIKE S |  |  |  |  |  |  |  |  |  | 12-037 |  |  |  |  |  |  |  |  |  |  |  |  |  |  |  |  |  |  |  |  |  | XX | 12-018F | 12-053 |  |  |  | 12-045 | Aug 12 |
| 13643280a |  | EPICS Interface Development FY13 |  | 111d | 2012-08-15 A | 2013-08-30 A | 13643280 FS-40d | 100% |  | 2012-08-15 | 2013-01-30 |  |  |  | ELEC ENG [5.73 h]; COMP SCIENT [28.66 h] | 2,327.61 | 2,349.39 |  |  | 1178.88495 | 2357.7699 | MAHONEY K | 1 | 1 | H | MIKE S |  |  |  |  |  |  |  |  |  | 12-037 |  |  |  |  |  |  |  |  |  |  |  |  |  |  |  |  |  |  |  |  |  | XX | 12-018F | 12-053 |  |  |  | 12-045 |  |
| 13643130 |  | Test/QA ODH Monitoring Sys (PSS) |  | 80d | 2012-08-20 A | 2012-12-17 A | 13643125 | 100% |  | 2012-08-20 | 2012-12-12 |  |  |  | ELEC ENG [40 h]; ELEC TECH [80 h] | 6,482.09 | 6,484.74 |  |  | 0 | 6352.8 | MAHONEY K | 1 | 1 | H | MIKE S |  |  |  |  |  |  |  |  |  | 12-037F |  |  |  |  |  |  |  |  |  |  |  |  |  |  |  |  |  |  |  |  |  |  |  |  |  |  |  |  | Aug 12 |

Notes:
- 13642020: Entry Criteria: Ext Pred: BOD Tagger Bldg, / Tagger Magnet Installed and Operational
- 23642913LOE: BOE NOTES: Demands for management reports such as this were not in estimate.
- 23642005: Steps: Program Development; Design Review; Program Test; EPICS Interface Development
- 23642014: Steps: Procure BELS Cable and Connectors; Procure BELS - EPICS Interface Components; Procure BELS Communication Components / BOE NOTES: Model Has recent price increase.
- 23642914LOE: BOE NOTES: Based on experience supporting 12GeV project. Addition is due to extending effort in to Fy14.
- 23642015: Steps: Test BELS Current Transducers; Test BELS PLC Systems; Test BELS Rack Components; Test BELS Communication Components
- 23642019: Steps: Finalize Documentation; Procure EPICS Interface Components; Procure BCM Interface Components (BSY) / BOE NOTES: Model Has recent price increase.
- 23642020: Entry Criteria: Ext Pred: BOD Tagger Bldg, / Tagger Magnet Installed and Operational / Steps: Finalize Documentation; Install Tagger Electronics; Tagger Cabinet and Field Wiring; Install Tagger - EPICS Interface; Install BSY Hall D Interface Electronics; Install Hall D BCM Interface; As-Built Documentation
- 13643911LOE: Steps: Management and Support for RF installation (done); Management and Support (done)
- 13643035a: Steps: Q.A. Incoming Parts (done); Prepare Test Station for Assemblies (done); Inspect and Q.A. Assemblies (done); Bench Test and Store Assemblies (done)
- 13643035ab: Steps: Q.A. Incoming Parts (done); Prepare Test Station for Assemblies (done); Inspect and Q.A. Assemblies (done); Bench Test and Store Assemblies (done)
- 13643035abb: Steps: Q.A. Incoming Parts (done); Prepare Test Station for Assemblies (done); Inspect and Q.A. Assemblies (done); Bench Test and Store Assemblies (done)
- 13643045: Steps: Install Hall D Conduit/Box Duct (done); Install Counting House Conduit/Box Duct (done); Install Counting House Rack (done); Install Tagger Conduit/Box Duct (done); Install Tagger Equipment Building Box Duct (done); Install Hall D Trunk Cable (done); Install Tagger Trunk Cable (done); Install Tagger Racks (done); Install 5C Beam Line Box Duct (done)
- 13643045b: Steps: Install Hall D Conduit/Box Duct (done); Install Counting House Conduit/Box Duct (done); Install Counting House Rack (done); Install Tagger Conduit/Box Duct (done); Install Tagger Equipment Building Box Duct (done); Install Hall D Trunk Cable (done); Install Tagger Trunk Cable (done); Install Tagger Racks (done); Install 5C Beam Line Box Duct (done)
- 13643075: Entry Criteria: Ext Pred: Arc 10 Box supplies / installed, new CMs installed
- 13643085: Entry Criteria: Ext Pred: BOD Tagger / Bldg
- 13643090: Entry Criteria: Ext Pred: BOD Hall D
- 13643145: Entry Criteria: Ext Pred: BOD Tagger Bldg, Hall / D, Tunnel Ext
- 13643015: Entry Criteria: Ext Pred: BOD Tagger Bldg, BOD / Hall D

| ID | Activity | Type | Duration | Start | Finish | Predecessors | Complete | Remaining | Planned start | Planned finish | Total float | Free float | Calendar | Resources | Cost | Actual cost | Calculated Remaining Total Cost | MONTHLY EV COST | RESP - Responsibility | STRT%COMP for CM EVM | FNSH%COMP for CM EVM | EVMS Reporting Codes | CAM RESPONSIBLE | CR 12-018 | CR 12-037 | CR 12-045 | New H Claim | Installation | OPC Allison | CR 12-053 | MARCH!!! | Remaining Material Cost Based on % Compl | Claimed Material Cost Based on % Complet | Initial Claimed Material Calc | Claimed Material Divider | CR 10-031 | CR 10-064 | CR 13-003 | LOE % Pre Calc | LOE % | LOE Divider | LOE Multiplier | Activities with Steps | Milestone Level | CR 10-065 | CR 10-066 | CR 10-059 | CR 11-044 | ReBaseline Actuals Adjustment | Original Activity ID Rebaseline | BOE Procurement | Post Rebaseline | Obligated Prior to Rebaseline | BOE Labor | BOE Expenses | CR 13-015 | CR 14-001 | PRIOR MONTH EV COST |
| --- | --- | --- | --- | --- | --- | --- | --- | --- | --- | --- | --- | --- | --- | --- | --- | --- | --- | --- | --- | --- | --- | --- | --- | --- | --- | --- | --- | --- | --- | --- | --- | --- | --- | --- | --- | --- | --- | --- | --- | --- | --- | --- | --- | --- | --- | --- | --- | --- | --- | --- | --- | --- | --- | --- | --- | --- | --- | --- |
| 13643225 | Design 5C Line ODH Monitoring |  | 61d | 2012-08-20 A | 2012-11-13 A | 9-120M FS+205d | 100% |  |  |  |  |  |  | ELEC ENG [60 h]; ELEC TECH [20 h]; ELEC DES [12 h] | 5,818.07 | 5,818.07 | 0 | 5722.32 | MAHONEY K | 1 | 1 | H | MIKE S | 12-018F | 12-037 | 12-045 | Aug 12 |  |  |  |  |  |  |  |  |  |  |  |  |  |  |  |  |  |  |  |  |  |  |  |  |  |  |  |  |  |  |  |
| 13643230 | Design HD Tagger ODH Monitoring |  | 18d | 2012-08-20 A | 2012-09-14 A | 9-120M FS+205d | 100% |  | 2012-08-20 | 2012-09-13 |  |  |  | ELEC ENG [30 h]; ELEC TECH [20 h]; ELEC DES [8 h] | 3,403.48 | 3,403.48 | 0 | 3403.48 | MAHONEY K | 1 | 1 | H | MIKE S | 12-018F | 12-037 | 12-045 | Aug 12 |  |  |  |  |  |  |  |  |  |  |  |  |  |  |  |  |  |  |  |  |  |  |  |  |  |  |  |  |  |  |  |
| 13643235 | Design Review (Internal) |  | 9d | 2012-08-27 A | 2012-09-10 A | 13643225 FS-10d, 13643230 FS-10d | 100% |  | 2012-08-27 | 2012-09-07 |  |  |  | ELEC ENG [32 h] | 2,257.92 | 2,257.92 | 0 | 2257.92 | MAHONEY K | 1 | 1 | H | MIKE S | 12-018F | 12-037 | 12-045 | Aug 12 |  |  |  |  |  |  |  |  |  |  |  |  |  |  |  |  |  |  |  |  |  |  |  |  |  |  |  |  |  |  |  |
| 13643135 | Install & Test ODH Monitoring Sys (PSS) |  | 81d | 2012-08-28 A | 2012-12-17 A | 16332010U, 16332010, 16333030, 13643130 FS-50d | 100% |  | 2012-08-28 | 2012-12-21 |  |  |  | COMP SCIENT [40 h]; ELEC TECH [120 h] | 8,101.42 | 8,097.69 | 0 | 7920.4 | MAHONEY K | 1 | 1 | H | MIKE S |  | 12-037F |  | Aug 12 | Install | OPC A |  |  |  |  |  |  |  |  |  |  |  |  |  |  |  |  |  |  |  |  |  |  |  |  |  |  |  |  |  |
| 13643260 | Hall D ODH Installation |  | 77d | 2012-08-28 A | 2012-12-17 A | 13643255 FS-20d | 100% |  |  |  |  |  |  | ELEC TECH [80 h]; SKLLD TRADE [40 h]; ELEC ENG [4 h] | 5,266.08 | 5,266.08 | 0 | 5315.24 | MAHONEY K | 1 | 1 | H | MIKE S | 12-018F | 12-037 | 12-045 | Aug 12 |  |  |  |  |  |  |  |  |  |  |  |  |  |  |  |  |  |  |  |  |  |  |  |  |  |  |  |  |  |  |  |
| 13643270 | QA Equipment FY12 |  | 74d | 2012-09-03 A | 2012-12-17 A | 13643235 FS+15d | 100% |  | 2012-09-04 | 2012-12-18 |  |  |  | ELEC ENG [2.57 h]; ELEC TECH [6.86 h]; SUPPLIES & MATERIALS | 581.27 | 495.51 | 0 | 569.781 | MAHONEY K | 1 | 1 | H | MIKE S | 12-018F | 12-037 | 12-045 |  |  |  | 12-053 |  |  |  |  |  |  |  |  |  |  |  |  |  |  |  |  |  |  |  |  |  |  |  |  |  |  |  |  |
| 13643270a | QA Equipment FY13 |  | 74d | 2012-09-03 A | 2012-12-17 A | 13643270 FS-40d | 100% |  | 2012-09-04 | 2012-12-18 |  |  |  | ELEC ENG [3.43 h]; ELEC TECH [9.14 h]; SUPPLIES & MATERIALS | 778.63 | 660.61 | 0 | 783.9139 | MAHONEY K | 1 | 1 | H | MIKE S | 12-018F | 12-037 | 12-045 |  |  |  | 12-053 |  |  |  |  |  |  |  |  |  |  |  |  |  |  |  |  |  |  |  |  |  |  |  |  |  |  |  |  |
| 13643275 | Modify PSS Racks FY12 |  | 21d | 2012-09-17 A | 2012-10-15 A | 9-120M FS+241d | 100% |  |  |  |  |  |  | ELEC ENG [1 h]; ELEC TECH [12 h]; SUPPLIES & MATERIALS | 710.16 | 610.16 | 0 | 700.12 | MAHONEY K | 1 | 1 | H | MIKE S | 12-018F | 12-037 | 12-045 |  |  |  | 12-053 |  |  |  |  |  |  |  |  |  |  |  |  |  |  |  |  |  |  |  |  |  |  |  |  |  |  |  |  |
| 13643275a | Modify PSS Racks FY13 |  | 21d | 2012-09-17 A | 2012-10-15 A | 13643275 FS-15d | 100% |  |  |  |  |  |  | ELEC ENG [1 h]; ELEC TECH [12 h]; SUPPLIES & MATERIALS | 713.35 | 610.16 | 0 | 722.48 | MAHONEY K | 1 | 1 | H | MIKE S | 12-018F | 12-037 | 12-045 |  |  |  | 12-053 |  |  |  |  |  |  |  |  |  |  |  |  |  |  |  |  |  |  |  |  |  |  |  |  |  |  |  |  |
| 13643325 | Install Local Alarms |  | 41d | 2012-09-17 A | 2012-11-12 A | 13643260 FS-25d | 100% |  |  |  |  |  |  | ELEC TECH [16 h] | 723.14 | 723.14 | 0 | 728.64 | MAHONEY K | 1 | 1 | H | MIKE S | 12-018F | 12-037 | 12-045 |  |  |  |  |  |  |  |  |  |  |  |  |  |  |  |  |  |  |  |  |  |  |  |  |  |  |  |  |  |  |  |  |
| 13643245 | 5 C Line ODH Installation FY12 |  | 59d | 2012-09-24 A | 2013-02-15 A | 13643240 FS-26d | 100% |  | 2012-09-24 | 2012-12-17 |  |  |  | SKLLD TRADE [14.86 h]; ELEC ENG [2.48 h]; ELEC TECH [37.14 h] | 2,378.64 | 2,381.05 | 0 | 2311.044 | MAHONEY K | 1 | 1 | H | MIKE S | 12-018F | 12-037 | 12-045 |  |  |  | 12-053 | XX |  |  |  |  |  |  |  |  |  |  |  |  |  |  |  |  |  |  |  |  |  |  |  |  |  |  |  |
| 13643245a | 5 C Line ODH Installation FY13 |  | 58d | 2012-09-24 A | 2013-02-15 A | 13643245 FS-20d | 100% |  | 2012-09-24 | 2012-12-14 |  |  |  | ELEC ENG [1.52 h]; ELEC TECH [22.86 h]; SKLLD TRADE [9.14 h] | 1,463.32 | 1,464.86 | 0 | 1467.2284 | MAHONEY K | 1 | 1 | H | MIKE S | 12-018F | 12-037 | 12-045 |  |  |  | 12-053 | XX |  |  |  |  |  |  |  |  |  |  |  |  |  |  |  |  |  |  |  |  |  |  |  |  |  |  |  |
| 13643020 | Proc PLC Systems (PSS) |  | 69d | 2012-10-01 A | 2012-12-17 A | 9-110M, 121643140, 9-130M FS+15d, 9-120M FS+151d | 100% |  | 2012-10-01 | 2013-01-15 |  |  |  | PROCUREMENT<$50K 60; ELEC ENG [80 h] | 37,251.73 | 5,824.8 | 0 | 37071.73 | MAHONEY K | 1 | 1 | D | MIKE S |  | 12-037F |  |  |  | OPC A |  |  | 0 | 31426.93 | 3142693 | 100 | 10-031 | 10-064 |  |  |  |  |  |  |  |  |  |  |  |  |  |  |  |  |  |  |  |  |  |
| 13643020b | Proc Remaining Cable and PLC Systems |  | 69d | 2012-10-01 A | 2013-08-28 A | 9-130M FS+23d | 100% |  | 2012-10-01 | 2013-01-15 |  |  |  | PROCUREMENT<$50K 60 | 55,000 |  | 55000 | 55000 | MAHONEY K | 1 | 1 | D | MIKE S |  | 12-037F |  |  |  |  |  | XX | 0 | 55000 | 5500000 | 100 | 10-031 | 10-064 | 13-003 |  |  |  |  |  |  |  |  |  |  |  |  |  |  |  |  |  |  |  |  |
| 13643913LOE | FY13 Mngmnt & Supprt Effort for PSS |  | 248d | 2012-10-01 A | 2013-08-30 A | 13643912LOE | 100% |  | 2012-10-01 | 2013-09-30 |  |  |  | ELEC DES [364.07 h]; OFFICE [22.06 h]; SR STAFF [80.9 h]; ELEC ENG [180.19 h] | 42,178.55 | 42,201.88 | 7771.75346769 | 42178.544901 | MAHONEY K | 1 | 1 | E | MIKE S |  |  |  |  |  | OPC A |  |  |  |  |  |  |  |  |  | 8.06451612 | 91.93548387 | 100 | 100 |  |  |  |  |  |  |  |  |  |  |  |  |  |  |  |  |
| 13643320 | Program Local Electronics |  | 45d | 2012-10-05 A | 2012-12-09 A | 13643260 FS-15d | 100% |  | 2012-10-05 | 2012-12-10 |  |  |  | ELEC ENG [40 h] | 2,912.4 | 2,912.4 | 0 | 2912.4 | MAHONEY K | 1 | 1 | H | MIKE S | 12-018F | 12-037 | 12-045 |  |  |  |  |  |  |  |  |  |  |  |  |  |  |  |  |  |  |  |  |  |  |  |  |  |  |  |  |  |  |  |  |
| 13643330 | Install Alarm Segment Interface |  | 44d | 2012-10-08 A | 2012-12-09 A | 13643325 FS-25d | 100% |  | 2012-10-08 | 2012-12-10 |  |  |  | ELEC TECH [8 h] | 364.32 | 364.32 | 0 | 364.32 | MAHONEY K | 1 | 1 | H | MIKE S | 12-018F | 12-037 | 12-045 |  |  |  |  |  |  |  |  |  |  |  |  |  |  |  |  |  |  |  |  |  |  |  |  |  |  |  |  |  |  |  |  |
| 13643137 | Complete the Install & Test of ODH Monitoring Sys (PSS) |  | 28d | 2012-11-05 A | 2012-12-17 A | 9-130M FS+23d | 100% |  | 2012-11-05 | 2012-12-14 |  |  |  | ELEC TECH [42.2 h]; ELEC ENG [39.5 h] | 4,797.79 | 4,797.79 | 0 | 4797.783 | MAHONEY K | 1 | 1 | H | MIKE S |  | 12-037F |  |  |  |  |  |  |  |  |  |  |  |  | 13-003 |  |  |  |  |  |  |  |  |  |  |  |  |  |  |  |  |  |  |  |  |
| 13643335 | Software Checkout |  | 22d | 2012-11-12 A | 2012-12-14 A | 13643320 FS-11d | 100% |  | 2012-11-12 | 2012-12-13 |  |  |  | ELEC TECH [4 h]; ELEC ENG [8 h]; COMP SCIENT [8 h] | 1,306.32 | 1,306.32 | 0 | 1306.32 | MAHONEY K | 1 | 1 | H | MIKE S | 12-018F | 12-037 | 12-045 |  |  |  |  |  |  |  |  |  |  |  |  |  |  |  |  |  |  |  |  |  |  |  |  |  |  |  |  |  |  |  |  |
| 13643340 | Test and Commission |  | 9d | 2012-12-02 A | 2012-12-14 A | 13643325 FS-4d | 100% |  | 2013-01-02 | 2013-01-14 |  |  |  | ELEC TECH [8 h]; ELEC ENG [8 h]; COMP SCIENT [2 h] | 1,082.22 | 1,082.22 | 0 | 1082.22 | MAHONEY K | 1 | 1 | H | MIKE S | 12-018F | 12-037 | 12-045 |  |  |  |  |  |  |  |  |  |  |  |  |  |  |  |  |  |  |  |  |  |  |  |  |  |  |  |  |  |  |  |  |
| 13643140 | Upgrade MCC Console (PSS) |  | 5d | 2013-01-07 A | 2013-08-30 A | 13643135 | 100% |  | 2013-08-19 | 2013-08-23 |  |  |  | ELEC ENG [20 h]; ELEC TECH [120 h] | 6,921 | 6,921 | 3353.4 | 6706.8 | MAHONEY K | 1 | 1 | H | MIKE S |  | 12-037F |  |  |  | OPC A |  |  |  |  |  |  |  |  |  |  |  |  |  |  |  |  |  |  |  |  |  |  |  |  |  |  |  |  |  |
| 13643150 | Proc Equipment for H-A, B, C Upgrades (PSS) |  | 21d | 2013-01-07 A | 2013-08-30 A | 2-02M FS-175d, 9-120M FS+60d, 121643140, 9-130M FS+70d | 100% |  | 2013-02-01 | 2013-03-04 |  |  |  | PROCUREMENT<$50K 60 | 7,242.34 |  | 7242.34 | 7242.34 | MAHONEY K | 1 | 1 | D | MIKE S |  | 12-037F |  |  |  | OPC A |  | XX | 0 | 7242.34 | 724234 | 100 |  |  |  |  |  |  |  |  |  |  |  |  |  |  |  |  |  |  |  |  |  |  |  |
| 13643350 | PSS PLC Communications - Labor |  | 171d | 2013-02-14 A | 2013-08-30 A | 9-130M FS+80d | 100% |  | 2013-03-01 | 2013-10-30 |  |  |  | ELEC ENG [115.4 h]; ELEC TECH [46 h] | 10,540.14 | 10,497.11 | 9972.2583 | 10497.114 | MAHONEY K | 1 | 1 | S | MIKE S | 12-018F | 12-037 | 12-045 |  |  |  |  |  |  |  |  |  |  |  | 13-003 |  |  |  |  | ST |  |  |  |  |  |  |  |  |  |  |  |  |  |  |  |
| 13643205 | Install Public Address Sys (PSS) |  | 30d | 2013-02-21 A | 2013-08-30 A | 16331030, 16331032, 16332010, 13643210 FS-70d, 16332030, 16332010U, 16333030 | 100% |  | 2013-03-20 | 2013-04-30 |  |  |  | ELEC TECH [160 h]; ELEC ENG [40 h] | 10,198.8 | 10,198.8 | 5099.4 | 10198.8 | MAHONEY K | 1 | 1 | H | MIKE S | 12-018F | 12-037 |  |  | Install | OPC A |  |  |  |  |  |  |  |  |  |  |  |  |  |  |  |  |  |  |  |  |  |  |  |  |  |  |  |  |  |
| 13643345 | 5C Line ODH Extension Complete | milestone | 0d | 2013-03-01 A | 2013-03-01 A | 13643340, 13643245a, 13643335, 13643220, 13643255, 13643215a FS-1d, 13643270a, 13643275a, 13643235 FS-7d, 13643330, 13643280a FS-10d | 100% |  | 2013-04-01 | 2013-04-01 |  |  |  |  |  |  |  | 0 | MAHONEY K | 1 | 1 | M | MIKE S | 12-018F | 12-037 | 12-045 |  |  |  |  | XX |  |  |  |  |  |  |  |  |  |  |  |  |  |  |  |  |  |  |  |  |  |  |  |  |  |  |  |
| 13643025 | Test/QA PLC Systems (PSS) |  | 27d | 2013-03-04 A | 2013-08-30 A | 13643020b FS-70d, 13643020 | 100% |  | 2013-06-17 | 2013-07-24 |  |  |  | ELEC TECH [102.64 h]; ELEC ENG [136.85 h] | 14,638.28 | 14,638.28 | 7092.8196 | 14185.6392 | MAHONEY K | 1 | 1 | H | MIKE S |  | 12-037F |  |  |  | OPC A |  |  |  |  |  |  | 10-031 | 10-064 |  |  |  |  |  |  |  |  |  |  |  |  |  |  |  |  |  |  |  |  |  |
| 13643095 | Proc Matrl's for Beam Stoppers & Diffusers (PSS) |  | 44d | 2013-03-04 A | 2013-08-19 A | 121643170, 121643140, 9-130M FS+105d, 9-120M FS+229d | 100% |  | 2013-04-01 | 2013-05-31 |  |  |  | PROCUREMENT<$50K 60; MECH TECH [40 h]; ELEC ENG [80 h] | 21,547.18 | 7,659.2 | 10655.19 | 21310.38 | MAHONEY K | 1 | 1 | H | MIKE S |  | 12-037F |  |  |  |  |  |  | 0 | 13887.98 | 1388798 | 100 |  |  |  |  |  |  |  |  |  |  |  |  |  |  |  |  |  |  |  |  |  |  |  |
| 13643060 | Proc Beam Transport Monitor Compnts (PSS) |  | 22d | 2013-04-01 A | 2013-08-30 A | 121643170, 121643140, 9-130M FS+100d, 9-120M FS+152d | 100% |  | 2013-05-01 | 2013-05-31 |  |  |  | ELEC ENG [80 h]; ELEC DES [40 h]; PROCUREMENT<$50K 60 | 19,984.07 | 7,909.6 | 9869.835 | 19739.67 | MAHONEY K | 1 | 1 | H | MIKE S |  | 12-037F |  |  |  | OPC A |  |  | 0 | 12074.47 | 1207447 | 100 |  |  |  |  |  |  |  |  |  |  |  |  |  |  |  |  |  |  |  |  |  |  |  |
| 13643360 | C-100 RF Commissioning PSS Support |  | 98d | 2013-04-01 A | 2013-08-30 A | 9-130M | 100% |  | 2013-05-01 | 2013-09-18 |  |  |  | ELEC ENG [55 h]; ELEC TECH [351 h] | 19,989.09 | 19,989.09 | 11413.77039 | 19989.09 | MAHONEY K | 1 | 1 | S | MIKE S | 12-018F | 12-037 | 12-045 |  |  |  |  |  |  |  |  |  |  |  | 13-003 |  |  |  |  | ST |  |  |  |  |  |  |  |  |  |  |  |  |  |  |  |
| 13643355 | PSS PLC Communications - Procurements |  | 62d | 2013-05-01 A | 2013-08-30 A | 13643350 FS-114d | 100% |  | 2013-06-03 | 2013-08-28 |  |  |  | PROCUREMENT<$50K 60 | 9,500 |  | 4750 | 9500 | MAHONEY K | 1 | 1 | D | MIKE S | 12-018F | 12-037 | 12-045 |  |  |  |  |  | 0 | 9500 | 950000 | 100 |  |  | 13-003 |  |  |  |  |  |  |  |  |  |  |  |  |  |  |  |  |  |  |  |  |
| 13643100 | Fab & Test Beam Stoppers & Diffusers (PSS) |  | 37d | 2013-06-03 A | 2013-08-30 A | 13643095 FS-20d | 100% |  | 2013-07-19 | 2013-09-10 |  |  |  | MECH DES [40 h]; MECH TECH [200 h]; ELEC ENG [120 h]; MSHOP; ELEC TECH [80 h]; COMP SCIENT [80 h] | 42,237.16 | 28,957.6 | 20670.78 | 41341.56 | MAHONEY K | 1 | 1 | H | MIKE S |  | 12-037F |  |  |  | OPC A |  |  |  |  |  |  |  |  |  |  |  |  |  |  |  |  |  |  |  |  |  |  |  |  |  |  |  |  |  |
| 13643120 | Install & Test PSS Beam Current Monitor |  | 67d | 2013-07-08 A | 2013-08-30 A | 16333030, 13643115 FS-25d | 100% |  | 2013-11-22 | 2014-03-10 |  |  |  | COMP SCIENT [80 h]; ELEC ENG [40 h]; MECH TECH [80 h]; ELEC TECH [120 h] | 18,019.2 | 17,462.8 | 16922.8 | 16922.8 | MAHONEY K | 1 | 1 | H | MIKE S |  | 12-037F |  |  | Install |  |  |  |  |  |  |  |  |  |  |  |  |  |  |  |  |  |  |  |  |  |  |  |  |  |  |  |  |  |  |
| 13643172M | Linac RF PSS Systems Comp | milestone | 0d | 2013-08-19 A | 2013-08-19 A | 13643080, 13643165a FS+180d | 100% |  | 2013-09-03 | 2013-09-03 |  |  |  |  |  |  |  | 0 | MAHONEY K | 1 | 1 | M | MIKE S |  |  |  |  |  | OPC A |  | XX |  |  |  |  | 10-031 | 10-064 |  |  |  |  |  |  | 6 | 10-065 | 10-066 |  |  |  |  |  |  |  |  |  |  |  |  |
| 13643065 | Fab & Test Beam Transport Monitor (PSS) |  | 21d | 2013-08-30 A | 2013-08-30 A | 13643060, 32-03M | 100% |  | 2013-10-03 | 2013-10-31 |  |  |  | ELEC TECH [80 h] | 3,759.2 | 3,643.2 | 3530.4 | 3530.4 | MAHONEY K | 1 | 1 | H | MIKE S |  | 12-037F |  |  |  | OPC A |  |  |  |  |  |  |  |  |  |  |  |  |  |  |  |  |  |  |  |  |  |  |  |  |  |  |  |  |  |
| 13643070 | Install Beam Transport Monitor (PSS) |  | 42d | 2013-08-30 A | 2013-08-30 A | 13643065, 9-140M, 13643210 | 100% |  | 2013-11-01 | 2014-01-09 |  |  |  | ELEC TECH [80 h]; COMP SCIENT [160 h]; ELEC ENG [120 h] | 23,954 | 23,214 | 23214 | 23214 | MAHONEY K | 1 | 1 | H | MIKE S |  | 12-037 |  |  | Install | OPC A |  |  |  |  |  |  |  |  |  |  |  |  |  |  |  |  |  |  |  |  |  |  |  |  |  |  |  |  |  |
| 13643105 | Install Beam Stoppers & Diffusers (PSS) |  | 24d | 2013-08-30 A | 2013-08-30 A | 13643210, 16333030, 9-130M FS+145d, 13643100 FS+25d | 100% |  | 2013-11-19 | 2013-12-31 |  |  |  | MECH TECH [80 h] | 3,785.6 | 3,668.8 | 3668.8 | 3668.8 | MAHONEY K | 1 | 1 | H | MIKE S |  | 12-037 |  |  | Install | OPC A |  |  |  |  |  |  |  |  |  |  |  |  |  |  |  |  |  |  |  |  |  |  |  |  |  |  |  |  |  |
| 13643155 | Install & Test H-A, B, C Upgrades (PSS) |  | 45d | 2013-08-30 A | 2013-08-30 A | 13643150, 2-02M | 100% |  | 2013-12-09 | 2014-02-19 |  |  |  | ELEC ENG [40 h]; ELEC TECH [120 h] | 8,644 | 8,377.2 | 8377.2 | 8377.2 | MAHONEY K | 1 | 1 | H | MIKE S |  | 12-037 |  |  | Install | OPC A |  |  |  |  |  |  |  |  |  |  |  |  |  |  |  |  |  |  |  |  |  |  |  |  |  |  |  |  |  |
| 13643165 | Install & Test PSS Logic Programs |  | 44d | 2013-08-30 A | 2013-08-30 A | 9-130M FS+184d, 13643160, 13643090, 13643085 | 100% |  | 2013-09-24 | 2013-11-22 |  |  |  | ELEC TECH [32.97 h]; ELEC ENG [131.89 h] | 11,417.95 | 11,104.36 | 10761.1245 | 10761.1245 | MAHONEY K | 1 | 1 | H | MIKE S |  | 12-037F |  |  | Install | OPC A |  |  |  |  |  |  | 10-031 |  |  |  |  |  |  |  |  |  |  | 10-059 | 11-044 |  |  |  |  |  |  |  |  |  |  |
| 13643170M | Linac PSS Systems Comp | milestone | 0d | 2013-08-30 A | 2013-08-30 A | 13458050, 13643080 | 100% |  | 2013-09-03 | 2013-09-03 |  |  |  |  |  |  |  | 0 | MAHONEY K | 1 | 1 | M | MIKE S |  | 12-037F |  |  |  | OPC A |  | XX |  |  |  |  | 10-031 | 10-064 |  |  |  |  |  |  | 6 |  |  |  |  |  |  |  |  |  |  |  |  |  |  |
| 13643950 | Re-Baseline Actuals Adjustment |  | 1d | 2013-08-30 A | 2013-08-30 A |  | 100% |  | 2013-09-03 | 2013-09-03 |  |  |  | PROCUREMENT>$50K 69 NO ESCALATION | 219,696.91 |  |  | 219696.91 |  |  |  |  |  |  |  |  |  |  |  |  |  | 0 | 219696.91 | 21969691 | 100 |  |  |  |  |  |  |  |  |  |  |  |  |  | ADJ |  |  |  |  |  |  |  |  |  |
| 13643175M | Halls A, B, C PSS Systems Comp | milestone | 0d | 2013-08-30 A | 2013-08-30 A | 13643155 | 100% |  | 2014-02-19 | 2014-02-19 |  |  |  |  |  |  |  | 0 | MAHONEY K | 1 | 1 | M | MIKE S |  | 12-037 |  |  |  | OPC A |  |  |  |  |  |  |  |  |  |  |  |  |  |  | 6 |  |  |  |  |  |  |  |  |  |  |  |  |  |  |
| 13643180M | Tagger Bldng PSS Systems Comp | milestone | 0d | 2013-08-30 A | 2013-08-30 A | 13643145, 13643137, 13643135 | 100% |  | 2013-10-31 | 2013-10-31 |  |  |  |  |  |  |  | 0 | MAHONEY K | 1 | 1 | M | MIKE S | 12-018F | 12-037 |  |  |  | OPC A |  |  |  |  |  |  |  |  |  |  |  |  |  |  | 6 |  |  |  |  |  |  |  |  |  |  |  |  |  |  |
| 13643185M | H-D PSS Systems Comp | milestone | 0d | 2013-08-30 A | 2013-08-30 A | 13643205, 16332030, 13643180M, 13643145 | 100% |  | 2013-10-31 | 2013-10-31 |  |  |  |  |  |  |  | 0 | MAHONEY K | 1 | 1 | M | MIKE S | 12-018F | 12-037 |  |  |  | OPC A |  |  |  |  |  |  |  |  |  |  |  |  |  |  | 6 |  |  |  |  |  |  |  |  |  |  |  |  |  |  |
| 23643020b | Proc Remaining Cable and PLC Systems |  | 43d | 2013-09-03 A | 2013-10-21 A | 9-130M FS+228d | 100% |  | 2013-10-01 | 2013-12-02 |  |  | 8/5 M-F w/JLAB Holidays ReBaseline | PROCUREMENT<$50K 60 | 4,278.8 |  |  | 4278.8 | MAHONEY K | 1 | 1 | S | MIKE S |  | 12-037F |  |  |  |  |  |  | 0 | 4278.8 | 427880 | 100 | 10-031 | 10-064 | 13-003 |  |  |  |  | ST |  |  |  |  |  |  | 23643020b | CP | PR | OB |  |  |  |  |  |
| 23643045 | Install Linac Cable Conduit, Infrastructure (PSS) FY13 |  | 32d | 2013-09-03 A | 2013-11-15 | 23643020b FS-43d |  | 11d | 2013-10-01 | 2013-11-13 | 88d | 9d | 8/5 M-F w/JLAB Holidays ReBaseline | ELEC TECH [36.3 h]; ELEC DES [3.63 h]; SKLLD TRADE [23.59 h]; PLABOR | 4,881.71 | 2,151.45 |  | 0 | MAHONEY K | 1 | 1 | S | MIKE S | 12-018F |  |  |  |  |  | 12-053 |  |  |  |  |  | 10-031 |  |  |  |  |  |  | ST |  |  |  | 10-059 | 11-044 |  | 23643045 |  | PR |  | PE | EV | 13-015 |  |  |
| 23643045a | Install Linac Cable Conduit, Infrastructure (PSS) FY14 |  | 12d | 2013-09-03 A | 2013-11-15 | 23643045 FS-20d |  | 11d | 2013-10-01 | 2013-10-16 | 88d | 12d | 8/5 M-F w/JLAB Holidays ReBaseline | ELEC TECH [21.78 h]; ELEC DES [2.18 h]; SKLLD TRADE [14.16 h]; PLABOR | 2,969.91 | 1,290.81 |  | 0 | MAHONEY K | 1 | 1 | S | MIKE S | 12-018F |  |  |  |  |  | 12-053 |  |  |  |  |  | 10-031 |  |  |  |  |  |  | ST |  |  |  | 10-059 | 11-044 |  | 23643045 |  | PR |  | PE | EV | 13-015 | 14-001 |  |
| 23643100 | Fab & Test Beam Stoppers & Diffusers (PSS) FY13 |  | 24d | 2013-09-03 A | 2013-11-20 | 9-130M FS+228d | 86% | 14d | 2013-10-01 | 2013-11-01 | 101d | 0d | 8/5 M-F w/JLAB Holidays ReBaseline | MECH DES [23.33 h]; MECH TECH [116.67 h]; MSHOP; ELEC ENG [70 h]; ELEC TECH [46.67 h] | 22,231.5 | 10,536 |  | 9327.82415433 | MAHONEY K | 1 | 1 | S | MIKE S |  | 12-037F |  |  |  |  |  |  |  |  |  |  |  |  |  |  |  |  |  | ST |  |  |  |  |  |  | 23643100 | PE | PR |  | PE | PE | 13-015 |  | 9349.618136 |
| 23643100a | Fab & Test Beam Stoppers & Diffusers (PSS) FY14 |  | 4d | 2013-09-03 A | 2013-11-20 | 23643100 FS-15d | 86% | 14d | 2013-09-03 | 2013-09-06 | 101d | 0d | 8/5 M-F w/JLAB Holidays ReBaseline | MECH DES [4.67 h]; MECH TECH [23.33 h]; MSHOP; ELEC ENG [14 h]; ELEC TECH [9.33 h] | 4,410 | 2,107.03 |  | 1924.9311342 | MAHONEY K | 1 | 1 | S | MIKE S |  | 12-037F |  |  |  |  |  |  |  |  |  |  |  |  |  |  |  |  |  | ST |  |  |  |  |  |  | 23643100 | PE | PR |  | PE | PE | 13-015 | 14-001 | 1929.42863685 |
| 23643117 | Proc BCM Cavity Components- (PSS) - Procurement |  | 43d | 2013-09-03 A | 2013-09-16 A | 9-130M FS+228d | 100% |  | 2013-10-01 | 2013-12-02 |  |  | 8/5 M-F w/JLAB Holidays ReBaseline | PROCUREMENT<$50K 60; MSHOP | 6,751.92 |  |  | 0 | MAHONEY K | 1 | 1 | S | MIKE S |  | 12-037F |  |  |  |  |  |  | 0 | 6751.92 | 675192 | 100 |  |  |  |  |  |  |  | ST |  |  |  |  |  |  | 23643117 | PE | PR | OB |  | PE | 13-015 |  | 6751.92 |
| 23643117a | Proc BCM Cavity Components- (PSS) Expenses FY13 |  | 20d | 2013-09-03 A | 2013-09-16 A | 9-130M FS+228d | 100% |  | 2013-09-03 | 2013-09-30 |  |  | 8/5 M-F w/JLAB Holidays ReBaseline | MSHOP | 465.12 |  |  | 0 | MAHONEY K | 1 | 1 | S | MIKE S |  | 12-037F |  |  |  |  |  |  |  |  |  |  |  |  |  |  |  |  |  | ST |  |  |  |  |  |  | 23643117 | PE | PR |  |  | PE | 13-015 |  | 465.12 |
| 23643117b | Proc BCM Cavity Components- (PSS) Expenses FY14 |  | 23.5d | 2013-09-03 A | 2013-09-16 A | 23643117a | 100% |  | 2013-10-01 | 2013-11-01 |  |  | 8/5 M-F w/JLAB Holidays ReBaseline | MSHOP | 551.94 |  |  | 0 | MAHONEY K | 1 | 1 | S | MIKE S |  | 12-037F |  |  |  |  |  |  |  |  |  |  |  |  |  |  |  |  |  | ST |  |  |  |  |  |  | 23643117 | PE | PR |  |  | PE | 13-015 | 14-001 | 551.94 |
| 23643140 | Upgrade MCC Console (PSS) FY13 |  | 31d | 2013-09-03 A | 2013-11-15 | 9-130M FS+228d | 50% | 11d | 2013-10-01 | 2013-11-12 | 95d | 9d | 8/5 M-F w/JLAB Holidays ReBaseline | ELEC TECH [69.68 h]; ELEC ENG [11.61 h] | 4,146.6 | 2,592.66 |  | 1117.17892038 | MAHONEY K | 1 | 1 | S | MIKE S |  | 12-037F |  |  |  |  |  |  |  |  |  |  |  |  |  |  |  |  |  | ST |  |  |  |  |  |  | 23643140 |  | PR |  | PE |  | 13-015 |  | 892.13568462 |
| 23643140a | Upgrade MCC Console (PSS) FY14 |  | 11d | 2013-09-03 A | 2013-11-15 | 23643140 FS-20d | 50% | 11d | 2013-10-01 | 2013-10-15 | 95d | 33d | 8/5 M-F w/JLAB Holidays ReBaseline | ELEC TECH [38.32 h]; ELEC ENG [6.39 h] | 2,280.66 | 1,425.98 |  | 634.02267492 | MAHONEY K | 1 | 1 | S | MIKE S |  | 12-037F |  |  |  |  |  |  |  |  |  |  |  |  |  |  |  |  |  | ST |  |  |  |  |  |  | 23643140 |  | PR |  | PE |  | 13-015 | 14-001 | 506.30587708 |
| 23643350 | PSS PLC Communications - Labor FY13 |  | 53d | 2013-09-03 A | 2013-11-27 | 9-130M FS+237d |  | 19d | 2013-10-01 | 2013-12-16 | 124d | 21d | 8/5 M-F w/JLAB Holidays ReBaseline | ELEC ENG [16.39 h]; ELEC TECH [6.54 h] | 1,538.83 | 1,051.92 |  | 0 | MAHONEY K | 1 | 1 | S | MIKE S | 12-018F | 12-037 | 12-045 |  |  |  |  |  |  |  |  |  |  |  | 13-003 |  |  |  |  | ST |  |  |  |  |  |  | 23643350 |  | PR |  | EJ |  | 13-015 |  |  |
| 23643350a | PSS PLC Communications - Labor FY14 |  | 42d | 2013-09-03 A | 2013-11-27 | 23643350 FS-45d |  | 19d | 2013-10-01 | 2013-11-27 | 124d | 21d | 8/5 M-F w/JLAB Holidays ReBaseline | ELEC ENG [62.59 h]; ELEC TECH [24.95 h] | 5,874.8 | 4,015.94 |  | 0 | MAHONEY K | 1 | 1 | S | MIKE S | 12-018F | 12-037 | 12-045 |  |  |  |  |  |  |  |  |  |  |  | 13-003 |  |  |  |  | ST |  |  |  |  |  |  | 23643350 |  | PR |  | EJ |  | 13-015 | 14-001 |  |
| 23643360 | C-100 RF Commissioning PSS Support |  | 20d | 2013-09-03 A | 2013-09-23 A | 9-130M FS+228d | 100% |  | 2013-10-01 | 2013-10-28 |  |  | 8/5 M-F w/JLAB Holidays ReBaseline | ELEC ENG [8.25 h]; ELEC TECH [52.65 h] | 3,093.84 | 2,998.36 |  | 0 | MAHONEY K | 1 | 1 | S | MIKE S | 12-018F | 12-037 | 12-045 |  |  |  |  |  |  |  |  |  |  |  | 13-003 |  |  |  |  | ST |  |  |  |  |  |  | 23643360 |  | PR |  | PE |  | 13-015 |  | 2998.3635 |
| 23643913LOE | FY13 Mngmnt & Supprt Effort for PSS |  | 20d | 2013-09-03 A | 2013-09-30 A | 9-130M FS+228d | 100% |  | 2013-10-01 | 2013-10-28 |  |  | 8/5 M-F w/JLAB Holidays ReBaseline | OFFICE [1.94 h]; ELEC ENG [15.8 h]; ELEC DES [31.93 h]; SCIENTIST [8.05 h] | 3,568.66 | 3,458.49 |  | 0 | MAHONEY K | 1 | 1 | E | MIKE S |  |  |  |  |  |  |  |  |  |  |  |  |  |  |  |  |  | 100 | 100 |  |  |  |  |  |  |  | 23643913LOE |  | PR |  | PE |  | 13-015 |  | 3458.490783 |
| 23643145 | Install & Test Tagger Access Control Sys (PSS) FY13 |  | 53d | 2013-09-16 A | 2013-11-27 | 23643045a FS-23d, 23643045 FS-23d |  | 19d | 2013-10-01 | 2013-12-16 | 87d | 11d | 8/5 M-F w/JLAB Holidays ReBaseline | ELEC TECH [39.52 h]; ELEC ENG [11.62 h]; ELEC DES [5.81 h] | 3,042.59 | 1,932.37 |  | 0 | MAHONEY K | 1 | 1 | S | MIKE S | 12-018F | 12-037 |  |  |  |  |  |  |  |  |  |  |  |  |  |  |  |  |  | ST |  |  |  |  |  |  | 23643145 |  | PR |  | PE |  | 13-015 |  |  |
| 23643145a | Install & Test Tagger Access Control Sys (PSS) FY14 |  | 42d | 2013-09-16 A | 2013-11-27 | 23643145 FS-45d, 23643045a FS-23d |  | 19d | 2013-10-01 | 2013-11-27 | 87d | 11d | 8/5 M-F w/JLAB Holidays ReBaseline | ELEC TECH [150.88 h]; ELEC ENG [44.38 h]; ELEC DES [22.19 h] | 11,617.42 | 7,378.27 |  | 0 | MAHONEY K | 1 | 1 | S | MIKE S | 12-018F | 12-037 |  |  |  |  |  |  |  |  |  |  |  |  |  |  |  |  |  | ST |  |  |  |  |  |  | 23643145 |  | PR |  | PE |  | 13-015 | 14-001 |  |
| 23643145b | Install & Test Hall D-MCC Access Control Sys (PSS) FY13 |  | 64d | 2013-09-16 A | 2013-12-16 | 23643045 FS-23d, 23643045a FS-23d |  | 30d | 2013-10-01 | 2014-01-10 | 76d | 0d | 8/5 M-F w/JLAB Holidays ReBaseline | ELEC TECH [37.4 h]; ELEC ENG [11 h]; ELEC DES [5.5 h] | 2,879.65 | 1,514.53 |  | 0 | MAHONEY K | 1 | 1 | S | MIKE S | 12-018F | 12-037 |  |  |  |  |  |  |  |  |  |  |  |  |  |  |  |  |  | ST |  |  |  |  |  |  | 23643145b |  | PR |  | PE |  | 13-015 |  |  |
| 23643145ba | Install & Test Hall D-MCC Access Control Sys (PSS) FY14 |  | 53d | 2013-09-16 A | 2013-12-16 | 23643045a FS-23d, 23643145b FS-55d |  | 30d | 2013-10-01 | 2013-12-16 | 76d | 0d | 8/5 M-F w/JLAB Holidays ReBaseline | ELEC TECH [180.2 h]; ELEC ENG [53 h]; ELEC DES [26.5 h] | 13,874.66 | 7,297.31 |  | 0 | MAHONEY K | 1 | 1 | S | MIKE S | 12-018F | 12-037 |  |  |  |  |  |  |  |  |  |  |  |  |  |  |  |  |  | ST |  |  |  |  |  |  | 23643145b |  | PR |  | PE |  | 13-015 | 14-001 |  |
| 23643170M | Linac PSS Systems Comp | milestone | 0d | 2013-09-30 A | 2013-09-30 A | 23643360 | 100% |  | 2013-10-28 | 2013-10-28 |  |  | 8/5 M-F w/JLAB Holidays ReBaseline |  |  |  |  | 0 | MAHONEY K | 1 | 1 | M | MIKE S |  | 12-037F |  |  |  |  |  |  |  |  |  |  | 10-031 | 10-064 |  |  |  |  |  |  | 6 |  |  |  |  |  | 23643170M |  | PR |  |  |  | 13-015 |  |  |
| 23643914LOE | FY14 Mngmnt & Supprt Effort for PSS |  | 163d | 2013-10-01 A | 2014-06-02 | 23643913LOE | 14% | 140d | 2013-11-01 | 2014-07-03 | 142d |  | 8/5 M-F w/JLAB Holidays ReBaseline | OFFICE [20 h]; ELEC ENG [117.76 h]; ELEC DES [237.92 h]; SCIENTIST [60 h] | 26,761.45 | 3,776.15 |  | 3776.04008704 | MAHONEY K | 1 | 1 | E | MIKE S |  |  |  |  |  |  |  |  |  |  |  |  |  |  |  | 85.88957055 | 14.11042944 | 100 | 100 |  |  |  |  |  |  |  | 23643914LOE |  | PR |  | PE |  | 13-015 | 14-001 |  |
| 23643355 | PSS PLC Communications - Procurements |  | 21d | 2013-10-03 A | 2013-11-27 | 23643350 FS-40d, 23643350a FS-40d |  | 19d | 2013-11-05 | 2013-12-05 | 103d | 41d | 8/5 M-F w/JLAB Holidays ReBaseline | PROCUREMENT<$50K 60 | 9,803.05 |  |  | 0 | MAHONEY K | 1 | 1 | S | MIKE S | 12-018F | 12-037 | 12-045 |  |  |  |  |  | 9803.05 | 0 | 0 | 100 |  |  | 13-003 |  |  |  |  | ST |  |  |  |  |  |  | 23643355 | CP | PR | OB-2 |  |  | 13-015 | 14-001 |  |
| 23643105 | Install Beam Stoppers & Diffusers (PSS) FY13 |  | 11d | 2013-10-17 A | 2013-11-15 | 23643100a FS-20d, 23643100 FS-20d, 23643102 FS-60d | 20% | 11d | 2013-11-19 | 2013-12-05 | 95d | 4d | 8/5 M-F w/JLAB Holidays ReBaseline | MECH TECH [26.67 h] | 1,262.02 | 631.01 |  | 244.61724 | MAHONEY K | 1 | 1 | S | MIKE S |  | 12-037 |  |  |  |  |  |  |  |  |  |  |  |  |  |  |  |  |  | ST |  |  |  |  |  |  | 23643105 |  | PR |  | PE |  | 13-015 |  |  |
| 23643105a | Install Beam Stoppers & Diffusers (PSS) FY14 |  | 22d | 2013-10-17 A | 2013-11-15 | 23643105 FS-15d, 23643100a FS-20d | 20% | 11d | 2013-12-06 | 2014-01-16 | 95d | 33d | 8/5 M-F w/JLAB Holidays ReBaseline | MECH TECH [53.33 h] | 2,523.58 | 1,261.79 |  | 504.71512 | MAHONEY K | 1 | 1 | S | MIKE S |  | 12-037 |  |  |  |  |  |  |  |  |  |  |  |  |  |  |  |  |  | ST |  |  |  |  |  |  | 23643105 |  | PR |  | PE |  | 13-015 | 14-001 |  |
| 23643065 | Fab & Test Beam Transport Monitor (PSS) |  | 26d | 2013-11-01 | 2013-12-10 | 9-140M FS+9d |  |  |  |  | 51d | 0d | 8/5 M-F w/JLAB Holidays ReBaseline | ELEC TECH [68 h] | 3,195.32 |  |  | 0 | MAHONEY K | 1 | 1 | S | MIKE S |  | 12-037F |  |  |  |  |  |  |  |  |  |  |  |  |  |  |  |  |  | ST |  |  |  |  |  |  | 23643065 |  | PR |  | PE |  | 13-015 | 14-001 |  |
| 23643115 | Test/QA PSS Beam Current Monitor Compnts |  | 30d | 2013-11-01 | 2013-12-16 | 9-140M FS+23d |  |  |  |  | 72d | 13d | 8/5 M-F w/JLAB Holidays ReBaseline | ELEC ENG [12.94 h]; ELEC TECH [6.47 h] | 1,276.13 |  |  | 0 | MAHONEY K | 1 | 1 | S | MIKE S |  | 12-037F |  |  |  |  |  |  |  |  |  |  |  |  |  |  |  |  |  | ST |  |  |  |  |  |  | 23643115 |  | PR |  | PE |  | 13-015 | 14-001 |  |
| 23643120 | Install & Test PSS Beam Current Monitor |  | 47d | 2013-11-01 | 2014-01-21 | 23643115 FS-43d |  |  |  |  | 59d | 8d | 8/5 M-F w/JLAB Holidays ReBaseline | ELEC TECH [108 h]; ELEC ENG [36 h]; MECH TECH [72 h]; COMP SCIENT [72 h] | 16,217.28 |  |  | 0 | MAHONEY K | 1 | 1 | S | MIKE S |  | 12-037F |  |  |  |  |  |  |  |  |  |  |  |  |  |  |  |  |  | ST |  |  |  |  |  |  | 23643120 |  | PR |  | PE |  | 13-015 | 14-001 |  |
| 23643155 | Install & Test H-A, B, C Upgrades (PSS) |  | 54d | 2013-11-01 | 2014-01-30 | 23643150 FS-54d |  |  |  |  | 39d | 0d | 8/5 M-F w/JLAB Holidays ReBaseline | ELEC ENG [40 h]; ELEC TECH [120 h] | 8,644 |  |  | 0 | MAHONEY K | 1 | 1 | S | MIKE S |  | 12-037 |  |  |  |  |  |  |  |  |  |  |  |  |  |  |  |  |  | ST |  |  |  |  |  |  | 23643155 |  | PR |  | PE |  | 13-015 | 14-001 |  |

Notes:
- 13643135: Entry Criteria: Ext Pred: BOD Tagger Bldg, BOD / Tunnel Ext
- 13643260: Steps: Install Conduit and Infrastructure; install and Terminate Cable; Install Oxygen Monitors in Hall D; Install Electronics for Hall D Tagger
- 13643245: Steps: Install Conduit and Infrastructure; install and Terminate Cable; Install Oxygen Monitors in 5C Line; Install Electronics for 5C Line
- 13643245a: Steps: Install Conduit and Infrastructure; install and Terminate Cable; Install Oxygen Monitors in 5C Line; Install Electronics for 5C Line
- 13643137: Entry Criteria: Ext Pred: BOD Tagger Bldg, BOD / Tunnel Ext
- 13643340: Steps: Test and Commission Hall D ODH System; (New step)1
- 13643350: Steps: Complete PLC Communications Design Modification (done); Order Components (done); Install Components (done)
- 13643205: Entry Criteria: Ext Pred: BOD Tagger Bldg, Hall / D, Tunnel Ext
- 13643360: Steps: RF Commissioning PSS Support for NL22 (done); RF Commissioning PSS Support for NL23 (done); RF Commissioning PSS Support for NL24 (done); RF Commissioning PSS Support for NL25 (done); RF Commissioning PSS Support for NL26 (done); RF Commissioning PSS Support for SL22 (done); RF Commissioning PSS Support for SL26 (done)
- 13643120: Entry Criteria: Ext Pred: BOD Tunnel / Ext
- 13643070: Entry Criteria: Ext Pred: / Magnets Installed
- 13643105: Entry Criteria: Ext Pred: BOD Tunnel / Ext
- 23643020b: Steps: Procure Final PLC SW Lic/Module (done) / BOE NOTES: Based on experience to date with Accelerator upgrade, and Hall D ODH systems.
- 23643045: Steps: Install Hall D Local Cable; Install Tagger Local Cable
- 23643045a: Steps: Install Hall D Local Cable; Install Tagger Local Cable
- 23643100: Steps: Clean/Assemble Parts (done); Assemble Stopper/Diffusers (3) (done); Test Stoppers in Lab (done); Fab Switch Panels (3) (done); Final Cleaning and Assembly (done); Update EPICS Controls; Electrical/Pneumatic Testing (done) / BOE NOTES: Materials Prices volatile
- 23643100a: Steps: Clean/Assemble Parts (done); Assemble Stopper/Diffusers (3) (done); Test Stoppers in Lab (done); Fab Switch Panels (3) (done); Final Cleaning and Assembly (done); Update EPICS Controls; Electrical/Pneumatic Testing (done) / BOE NOTES: Materials Prices volatile
- 23643117: Steps: Machine Shop Fabrication (done); Procure Tuner, Couplings (done); Procure Components for fabrication (done) / BOE NOTES: Based on experience with other cavities, and I&C experience with MPS cavities.
- 23643117a: Steps: Machine Shop Fabrication (done); Procure Tuner, Couplings (done); Procure Components for fabrication (done) / BOE NOTES: Based on experience with other cavities, and I&C experience with MPS cavities.
- 23643117b: Steps: Machine Shop Fabrication (done); Procure Tuner, Couplings (done); Procure Components for fabrication (done) / BOE NOTES: Based on experience with other cavities, and I&C experience with MPS cavities.
- 23643140: Steps: Replace Panels (done); Install Tagger/Hall D Controls; Wire New Controls; Update Camera Sw. System (done); Test Console Controls (done)
- 23643140a: Steps: Replace Panels (done); Install Tagger/Hall D Controls; Wire New Controls; Update Camera Sw. System (done); Test Console Controls (done)
- 23643350: Steps: Final Implementation Review; Procurement Labor; Test/Configure Components; Field Test
- 23643350a: Steps: Final Implementation Review; Procurement Labor; Test/Configure Components; Field Test
- 23643360: Steps: RF Commissioning PSS Support for NL26 (done)
- 23643913LOE: BOE NOTES: Demands for management reports such as this were not in estimate.
- 23643145: Entry Criteria: Ext Pred: BOD Tagger Bldg, Hall / D, Tunnel Ext / Steps: Install Vault PSS Equipment; Install Access Room Equipment; Complete Rack Wiring; Complete Field Wiring; Test/QA Components; As-Built Documentation
- 23643145a: Entry Criteria: Ext Pred: BOD Tagger Bldg, Hall / D, Tunnel Ext / Steps: Install Vault PSS Equipment; Install Access Room Equipment; Complete Rack Wiring; Complete Field Wiring; Test/QA Components; As-Built Documentation
- 23643145b: Entry Criteria: Ext Pred: BOD Tagger Bldg, Hall / D, Tunnel Ext / Steps: Install Hall D PLC Electronics; Complete MCC Rack Wiring; Complete MCC Field Wiring; Install HD I/O Drop in Injector; Complete Injector Rack Wiring; Complete Injector Field Wiring; System Level Test; As-Built Documentation
- 23643145ba: Entry Criteria: Ext Pred: BOD Tagger Bldg, Hall / D, Tunnel Ext / Steps: Install Hall D PLC Electronics; Complete MCC Rack Wiring; Complete MCC Field Wiring; Install HD I/O Drop in Injector; Complete Injector Rack Wiring; Complete Injector Field Wiring; System Level Test; As-Built Documentation
- 23643914LOE: BOE NOTES: Based on experience supporting 12GeV project. Addition is due to extending effort in to Fy14.
- 23643355: Steps: Procure Comm. Hardware; Procure PLC Comm. Hardware; Procure Comm. Sec. Software / BOE NOTES: New hardware available that addresses known vulnerabilities.
- 23643105: Entry Criteria: Ext Pred: BOD Tunnel / Ext / Steps: Work Prep (done); Laiason with Stand Integration (done); Modify Dry Air Controls; Modify Nitrogen Gas Panel; Connect Pneumatics; Leak Test
- 23643105a: Entry Criteria: Ext Pred: BOD Tunnel / Ext / Steps: Work Prep (done); Laiason with Stand Integration (done); Modify Dry Air Controls; Modify Nitrogen Gas Panel; Connect Pneumatics; Leak Test
- 23643065: Steps: Build PLC Components; Test PLC Components; Characterize System
- 23643115: Steps: Test/QA PSS Beam Current Monitor Compnts / BOE NOTES: Adder due to personnel that engineered BCM is no longer at Jlab. Some learning curve applicable.
- 23643120: Entry Criteria: Ext Pred: BOD Tunnel / Ext / Steps: Install BCM Electronics; Install RF Electronics; Wire/Cable Hall D BCM Channel; Install Heliax; Install Field Wiring; Test/QA RF Components; Connect BCM and Calibrate / BOE NOTES: Adder due to personnel that engineered BCM is no longer at Jlab. Some learning curve applicable.
- 23643155: Steps: Hall A PSS Upgrade Support; Hall B PSS Upgrade Support; Hall C PSS Upgrade Support; As-Built Documentation / BOE NOTES: Emerging Requirements for Endstation PSS/MPS may delay until FY14-FY15

| ID | WBS | Activity | Type | Duration | Start | Finish | Predecessors | Complete | Remaining | Planned start | Planned finish | Total float | Free float | Calendar | Resources | Cost | Actual cost | Original Activity ID Rebaseline | Remaining Material Cost Based on % Compl | Claimed Material Cost Based on % Complet | Initial Claimed Material Calc | Claimed Material Divider | MONTHLY EV COST | RESP - Responsibility | STRT%COMP for CM EVM | FNSH%COMP for CM EVM | EVMS Reporting Codes | CAM RESPONSIBLE | Activities with Steps | CR 12-037 | BOE Procurement | Post Rebaseline | CR 14-001 | CR 12-018 | BOE Labor | CR 12-045 | CR 12-053 | CR 13-015 | BOE Expenses | Milestone Level | CR 10-031 | CR 10-059 | CR 11-044 | LOE Divider | LOE Multiplier | Calculated Remaining Total Cost | CR 08-058 | LOE % Pre Calc | LOE % | OPC Allison | CR 10-070 | CR 11-026 | CR 12-029 | CR 12-035 | CR 12-026 | MARCH!!! | Installation | CR 08-016 | CR 09-012 | ReBaseline Actuals Adjustment | PRIOR MONTH EV COST | Obligated Prior to Rebaseline |
| --- | --- | --- | --- | --- | --- | --- | --- | --- | --- | --- | --- | --- | --- | --- | --- | --- | --- | --- | --- | --- | --- | --- | --- | --- | --- | --- | --- | --- | --- | --- | --- | --- | --- | --- | --- | --- | --- | --- | --- | --- | --- | --- | --- | --- | --- | --- | --- | --- | --- | --- | --- | --- | --- | --- | --- | --- | --- | --- | --- | --- | --- | --- |
| 23643150 |  | Proc Equipment for H-A, B, C Upgrades (PSS) |  | 51d | 2013-11-04 | 2014-01-28 | 9-140M FS+24d |  |  |  |  | 41d | 2d | 8/5 M-F w/JLAB Holidays ReBaseline | PROCUREMENT<$50K 60 | 7,473.37 |  | 23643150 | 7473.37 | 0 | 0 | 100 | 0 | MAHONEY K | 1 | 1 | S | MIKE S | ST | 12-037F | PE | PR | 14-001 |  |  |  |  |  |  |  |  |  |  |  |  |  |  |  |  |  |  |  |  |  |  |  |  |  |  |  |  |  |
| 23643205 |  | Install Public Address Sys (PSS) |  | 29d | 2013-11-04 | 2013-12-16 | 9-140M FS+24d |  |  |  |  | 76d | 25d | 8/5 M-F w/JLAB Holidays ReBaseline | ELEC ENG [16 h]; ELEC TECH [64 h] | 4,209.44 |  | 23643205 |  |  |  |  | 0 | MAHONEY K | 1 | 1 | S | MIKE S | ST | 12-037 |  | PR | 14-001 | 12-018F | PE |  |  |  |  |  |  |  |  |  |  |  |  |  |  |  |  |  |  |  |  |  |  |  |  |  |  |  |
| 23643280 |  | EPICS Interface Development |  | 54d | 2013-11-04 | 2014-01-31 | 9-140M FS+24d |  |  |  |  | 51d | 35d | 8/5 M-F w/JLAB Holidays ReBaseline | ELEC ENG [40 h]; COMP SCIENT [120 h] | 11,389.6 |  | 23643280 |  |  |  |  | 0 | MAHONEY K | 1 | 1 | S | MIKE S | ST | 12-037 |  | PR | 14-001 | 12-018F | PE | 12-045 | 12-053 | 13-015 |  |  |  |  |  |  |  |  |  |  |  |  |  |  |  |  |  |  |  |  |  |  |  |  |
| 23643070 |  | Install Beam Transport Monitor (PSS) |  | 34d | 2013-11-21 | 2014-01-22 | 23643065 FS-12d |  |  |  |  | 51d | 0d | 8/5 M-F w/JLAB Holidays ReBaseline | ELEC ENG [120 h]; COMP SCIENT [160 h]; ELEC TECH [80 h] | 23,954 |  | 23643070 |  |  |  |  | 0 | MAHONEY K | 1 | 1 | S | MIKE S | ST | 12-037 |  | PR | 14-001 |  | PE |  |  | 13-015 |  |  |  |  |  |  |  |  |  |  |  |  |  |  |  |  |  |  |  |  |  |  |  |  |
| 23643102 |  | Update Stopper/Diffuser Software (PSS) |  | 34d | 2013-11-21 | 2014-01-22 | 9-140M FS+23d, 23643100a, 23643100 |  |  |  |  | 107d | 12d | 8/5 M-F w/JLAB Holidays ReBaseline | COMP SCIENT [40 h] | 2,794.8 |  | 23643100 |  |  |  |  | 0 | MAHONEY K | 1 | 1 | S | MIKE S | ST | 12-037F | PE | PR | 14-001 |  | PE |  |  | 13-015 | PE |  |  |  |  |  |  |  |  |  |  |  |  |  |  |  |  |  |  |  |  |  |  |  |
| 23643160 |  | Create & Simulate PSS Logic Programs |  | 24d | 2013-12-03 | 2014-01-15 | 9-140M FS+43d |  |  |  |  | 62d | 0d | 8/5 M-F w/JLAB Holidays ReBaseline | ELEC ENG [120 h] | 9,015.6 |  | 23643160 |  |  |  |  | 0 | MAHONEY K | 1 | 1 | S | MIKE S | ST | 12-037F |  | PR | 14-001 |  | PE |  |  |  |  |  |  |  |  |  |  |  |  |  |  |  |  |  |  |  |  |  |  |  |  |  |  |  |
| 23643180M |  | Tagger Bldng PSS Systems Comp | milestone | 0d | 2013-12-16 | 2013-12-16 | 23643145a, 23643145ba, 23643145, 23643145b |  |  |  |  | 76d | 25d | 8/5 M-F w/JLAB Holidays ReBaseline |  |  |  | 23643180M |  |  |  |  | 0 | MAHONEY K | 1 | 1 | M | MIKE S |  | 12-037 |  | PR |  | 12-018F |  |  |  | 13-015 |  | 6 |  |  |  |  |  |  |  |  |  |  |  |  |  |  |  |  |  |  |  |  |  |  |
| 23643070a |  | Install Beam Transport Monitor - EPICS Interface (PSS) |  | 22d | 2013-12-20 | 2014-01-31 | 23643070 FS-15d, 23643065 FS-12d |  |  |  |  | 51d | 0d | 8/5 M-F w/JLAB Holidays ReBaseline | COMP SCIENT [120 h]; ELEC ENG [40 h] | 11,389.6 |  | 23643070a |  |  |  |  | 0 | MAHONEY K | 1 | 1 | S | MIKE S | ST | 12-037 |  | PR | 14-001 |  | PE |  |  | 13-015 |  |  |  |  |  |  |  |  |  |  |  |  |  |  |  |  |  |  |  |  |  |  |  |  |
| 23643165 |  | Install & Test PSS Logic Programs |  | 10d | 2014-01-02 | 2014-01-15 | 23643160 FS-10d |  |  |  |  | 62d | 0d | 8/5 M-F w/JLAB Holidays ReBaseline | ELEC TECH [32.97 h]; ELEC ENG [131.89 h] | 11,458.16 |  | 23643165 |  |  |  |  | 0 | MAHONEY K | 1 | 1 | S | MIKE S | ST | 12-037F |  | PR | 14-001 |  | PE |  |  | 13-015 |  |  | 10-031 | 10-059 | 11-044 |  |  |  |  |  |  |  |  |  |  |  |  |  |  |  |  |  |  |  |
| 23643175M |  | Halls A, B, C PSS Systems Comp | milestone | 0d | 2014-01-30 | 2014-01-30 | 23643155 |  |  |  |  | 39d | 26d | 8/5 M-F w/JLAB Holidays ReBaseline |  |  |  | 23643175M |  |  |  |  | 0 | MAHONEY K | 1 | 1 | M | MIKE S |  | 12-037 |  | PR |  |  |  |  |  | 13-015 |  | 6 |  |  |  |  |  |  |  |  |  |  |  |  |  |  |  |  |  |  |  |  |  |  |
| 23643185M |  | H-D PSS Systems Comp | milestone | 0d | 2014-01-31 | 2014-01-31 | 23643145ba, 23643145b, 23643145, 23643180M, 23643205, 23643145a, 23643070, 23643120, 23643070a |  |  |  |  | 51d | 35d | 8/5 M-F w/JLAB Holidays ReBaseline |  |  |  | 23643185M |  |  |  |  | 0 | MAHONEY K | 1 | 1 | M | MIKE S |  | 12-037 |  | PR |  | 12-018F |  |  |  | 13-015 |  | 6 |  |  |  |  |  |  |  |  |  |  |  |  |  |  |  |  |  |  |  |  |  |  |
|  | 5 | **1.3.6.5 DUMPS (HALL D & INSERTABLE)** |  |  | 2009-01-02 | 2014-02-20 |  |  |  |  |  |  |  |  |  |  |  |  |  |  |  |  |  |  |  |  |  |  |  |  |  |  |  |  |  |  |  |  |  |  |  |  |  |  |  |  |  |  |  |  |  |  |  |  |  |  |  |  |  |  |  |  |
| 1365909LOE |  | FY09 Mngmnt Effort for Dump |  | 189d | 2009-01-02 A | 2009-09-30 A | 1365909LOEX | 100% |  |  |  |  |  |  | SR STAFF [3.05 h] | 313.66 | 313.66 |  |  |  |  |  | 313.662 | GARZA O | 1 | 1 | E | MIKE S |  |  |  |  |  |  |  |  |  |  |  |  |  |  |  | 100 | 100 | 0 | 08-058 |  |  |  |  |  |  |  |  |  |  |  |  |  |  |  |
| 1365910LOE |  | FY10 Mngmnt Effort for Dump |  | 248d | 2009-10-01 A | 2010-09-30 A | 1365909LOE | 100% |  |  |  |  |  |  | SR STAFF [4 h] | 424.48 | 424.48 |  |  |  |  |  | 424.48 | GARZA O | 1 | 1 | E | MIKE S |  |  |  |  |  |  |  |  |  |  |  |  |  |  |  | 100 | 100 | 0 |  |  |  |  |  |  |  |  |  |  |  |  |  |  |  |  |
| 1365911LOE |  | FY11 Mngmnt Effort for Dump |  | 248d | 2010-10-01 A | 2011-09-30 A | 1365910LOE | 100% |  |  |  |  |  |  | SR STAFF [24 h] | 2,628.24 | 2,628.24 |  |  |  |  |  | 2628.238675 | GARZA O | 1 | 1 | E | MIKE S |  |  |  |  |  |  |  |  |  |  |  |  |  |  |  | 100 | 100 | 0 |  | 8.46774193 | 91.53225806 |  |  |  |  |  |  |  |  |  |  |  |  |  |
| 1365912LOE |  | FY12 Mngmnt Effort for Dump |  | 247d | 2011-10-03 A | 2012-09-28 A | 1365911LOE | 100% |  |  |  |  |  |  | SR STAFF [24 h] | 2,712 | 2,712 |  |  |  |  |  | 2712 | GARZA O | 1 | 1 | E | MIKE S |  |  |  |  |  |  |  |  |  |  |  |  |  |  |  | 100 | 100 | 0 |  | 7.69230769 | 92.3076923 |  |  |  |  |  |  |  |  |  |  |  |  |  |
| 1365913LOE |  | FY13 Mngmnt Effort for Dump |  | 248d | 2012-10-01 A | 2013-08-30 A | 1365912LOE | 100% |  | 2012-10-01 | 2013-09-30 |  |  |  | SR STAFF [22.06 h] | 2,572.2 | 2,575.51 |  |  |  |  |  | 2572.196 | GARZA O | 1 | 1 | E | MIKE S |  |  |  |  |  |  |  |  |  |  |  |  |  |  |  | 100 | 100 | 474.04872114 |  | 8.06451612 | 91.93548387 | OPC A |  |  |  |  |  |  |  |  |  |  |  |  |
| 1365014 |  | HD Dump Sys Prcrmnts |  | 59d | 2012-10-05 A | 2013-08-30 A | 12165030, 12165035, 9-130M, 9-120M FS+140d | 100% |  | 2012-10-05 | 2013-01-07 |  |  |  | PROCUREMENT<$50K 60; ELEC ENG [80 h]; ELEC TECH [40 h] | 25,196.49 | 7,646.4 |  | 0 | 17550.09 | 1755009 | 100 | 24960.09 | GARZA O | 1 | 1 | H | MIKE S |  |  |  |  |  | 12-018F |  |  |  |  |  |  |  |  |  |  |  | 12480.045 |  |  |  | OPC A | 10-070 | 11-026 | 12-029F | 12-035F |  |  |  |  |  |  |  |  |
| 1365040 |  | Insertable Dump Sys Prcrmnts |  | 59d | 2012-10-05 A | 2013-04-15 A | 9-120M FS+60d, 12165035, 12165030, 9-130M | 100% |  | 2012-10-05 | 2013-01-07 |  |  |  | PROCUREMENT<$50K 60; ELEC TECH [40 h] | 13,521.66 | 1,821.6 |  | 0 | 11700.06 | 1170006 | 100 | 13465.26 | GARZA O | 1 | 1 | H | MIKE S |  |  |  |  |  | 12-018F |  |  |  |  |  |  |  |  |  |  |  | 0 |  |  |  | OPC A | 10-070 | 11-026 | 12-029F | 12-035F | 12-026F | XX |  |  |  |  |  |  |
| 1365015 |  | HD Dump Sys Fab & Assy |  | 20d | 2013-01-14 A | 2013-08-30 A | 1365014 FS-85d | 100% |  | 2013-06-03 | 2013-06-28 |  |  |  | ELEC ENG [80 h]; ELEC TECH [400 h]; PROCUREMENT<$50K 60; SUPPLIES & MATERIALS; ELEC DES [40 h] | 38,375.57 | 26,125.6 |  | 0 | 5850.04 | 585004 | 100 | 37567.17 | GARZA O | 1 | 1 | H | MIKE S |  |  |  |  |  | 12-018F |  |  |  |  |  |  |  |  |  |  |  | 18783.585 |  |  |  | OPC A | 10-070 | 11-026 | 12-029F | 12-035F |  |  | Install |  |  |  |  |  |
| 1365045 |  | Insertable Dump Sys Fab & Assy |  | 41d | 2013-01-14 A | 2013-08-30 A | 9-130M, 1365040 FS-40d | 100% |  | 2013-05-03 | 2013-07-01 |  |  |  | PROCUREMENT<$50K 60; SUPPLIES & MATERIALS; ELEC DES [80 h]; ELEC TECH [240 h] | 29,780.31 | 15,099.2 |  | 0 | 8451.3 | 845130 | 100 | 29780.31 | GARZA O | 1 | 1 | H | MIKE S |  |  |  |  |  | 12-018F |  |  |  |  |  |  |  |  |  |  |  | 14890.155 |  |  |  | OPC A | 10-070 | 11-026 | 12-029F | 12-035F | 12-026 |  | Install |  |  |  |  |  |
| 1365020 |  | HD Dump Component Testing |  | 64d | 2013-01-28 A | 2013-08-30 A | 9-130M, 1365015 FS-20d | 100% |  | 2013-07-31 | 2013-10-29 |  |  |  | ELEC ENG [320 h]; ELEC TECH [80 h]; COMP SCIENT [160 h] | 38,171.06 | 37,776 |  |  |  |  |  | 37776 | GARZA O | 1 | 1 | H | MIKE S |  |  |  |  |  | 12-018F |  |  |  |  |  |  |  |  |  |  |  | 18888 |  |  |  | OPC A | 10-070 | 11-026 | 12-029F | 12-035F | 12-026 |  |  |  |  |  |  |  |
| 1365025 |  | HD Dump Sys Implementn |  | 60d | 2013-01-28 A | 2013-08-30 A | 16331032, 16331030, 1365020 FS-65d | 100% |  | 2013-10-02 | 2014-01-03 |  |  |  | ELEC TECH [160 h]; ELEC DES [40 h]; PLABOR; PROCUREMENT<$50K 60 | 13,432.85 | 9,371.2 |  | 0 | 2414.67 | 241467 | 100 | 13134.45 | GARZA O | 1 | 1 | H | MIKE S |  |  |  |  |  | 12-018F |  |  |  |  |  |  |  |  |  |  |  | 6567.225 |  |  |  | OPC A | 10-070 | 11-026 | 12-029F | 12-035F | 12-026 |  |  | 08-016 | 09-012 |  |  |  |
| 1365050 |  | Insertable Dump Component Testing |  | 42d | 2013-01-28 A | 2013-08-30 A | 1365045 FS-45d | 100% |  | 2013-06-04 | 2013-08-01 |  |  |  | ELEC TECH [80 h]; ELEC ENG [40 h] | 6,555.6 | 6,555.6 |  |  |  |  |  | 6555.6 | GARZA O | 1 | 1 | H | MIKE S |  |  |  |  |  | 12-018F |  |  |  |  |  |  |  |  |  |  |  | 3277.8 |  |  |  | OPC A | 10-070 | 11-026 | 12-029F | 12-035F | 12-026 |  |  |  |  |  |  |  |
| 1365055 |  | Insertable Dump Sys Implementn |  | 41d | 2013-01-28 A | 2013-08-30 A | 1365050 FS-50d, 1362025 | 100% |  | 2013-01-28 | 2013-03-26 |  |  |  | ELEC DES [40 h]; PROCUREMENT<$50K 60; PLABOR; ELEC TECH [240 h] | 20,399.64 | 13,014.4 |  | 0 | 6036.66 | 603666 | 100 | 20399.64 | GARZA O | 1 | 1 | H | MIKE S |  |  |  |  |  | 12-018F |  |  |  |  |  |  |  |  |  |  |  | 10199.82 |  |  |  | OPC A | 10-070 | 11-026 | 12-029F | 12-035F | 12-026 |  |  | 08-016 | 09-012 |  |  |  |
| 1365030 |  | HD Dump Software Implementn & Cmmssng |  | 55d | 2013-08-30 A | 2013-08-30 A | 1365025 FS-41d | 100% |  | 2013-09-03 | 2013-11-18 |  |  |  | COMP SCIENT [320 h]; ELEC ENG [120 h]; ELEC TECH [80 h] | 34,738.43 | 34,047.6 |  |  |  |  |  | 34047.6 | GARZA O | 1 | 1 | H | MIKE S |  |  |  |  |  | 12-018F |  |  |  |  |  |  |  |  |  |  |  | 34047.6 |  |  |  | OPC A | 10-070 | 11-026 | 12-029F | 12-035F | 12-026 |  |  |  |  |  |  |  |
| 1365060 |  | Insertable Dump Software Implementn & Cmmssng |  | 75d | 2013-08-30 A | 2013-08-30 A | 1365055 FS-35d, 1363035 | 100% |  | 2013-09-03 | 2013-12-18 |  |  |  | ELEC ENG [200 h]; ELEC TECH [80 h]; COMP SCIENT [160 h] | 29,717.58 | 29,038.8 |  |  |  |  |  | 29038.8 | GARZA O | 1 | 1 | H | MIKE S |  |  |  |  |  | 12-018F |  |  |  |  |  |  |  |  |  |  |  | 29038.8 |  |  |  | OPC A | 10-070 | 11-026 | 12-029F | 12-035F | 12-026 |  |  |  |  |  |  |  |
| 1365950 |  | Re-Baseline Actuals Adjustment |  | 1d | 2013-08-30 A | 2013-08-30 A |  | 100% |  | 2013-09-03 | 2013-09-03 |  |  |  | PROCUREMENT>$50K 69 NO ESCALATION | -109,636.21 |  |  |  |  |  | 100 |  |  |  |  |  |  |  |  |  |  |  |  |  |  |  |  |  |  |  |  |  |  |  |  |  |  |  |  |  |  |  |  |  |  |  |  |  | ADJ |  |  |
| 1365035M |  | HD Dump Comp | milestone | 0d | 2013-08-30 A | 2013-08-30 A | 1365030 | 100% |  | 2013-11-18 | 2013-11-18 |  |  |  |  |  |  |  |  |  |  |  | 0 | GARZA O | 1 | 1 | M | MIKE S |  |  |  |  |  | 12-018F |  |  |  |  |  | 6 |  |  |  |  |  |  |  |  |  | OPC A | 10-070 | 11-026 | 12-029F | 12-035F | 12-026 |  |  |  |  |  |  |  |
| 1365065M |  | Insertable Dump Comp | milestone | 0d | 2013-08-30 A | 2013-08-30 A | 1365060 | 100% |  | 2013-12-18 | 2013-12-18 |  |  |  |  |  |  |  |  |  |  |  | 0 | GARZA O | 1 | 1 | M | MIKE S |  |  |  |  |  | 12-018F |  |  |  |  |  | 6 |  |  |  |  |  |  |  |  |  | OPC A | 10-070 | 11-026 | 12-029F | 12-035F | 12-026 |  |  |  |  |  |  |  |
| 2365045 |  | Insertable Dump Sys Fab & Assy |  | 19d | 2013-09-03 A | 2013-09-23 A | 9-140M | 100% |  | 2013-10-01 | 2013-10-25 |  |  | 8/5 M-F w/JLAB Holidays ReBaseline | ELEC TECH [48 h]; PROCUREMENT<$50K 60; SUPPLIES & MATERIALS; ELEC DES [16 h] | 4,288.47 | 3,019.84 | 2365045 | 0 | 918.66 | 91866 | 100 | 0 | GARZA O | 1 | 1 | H | MIKE S |  |  | EV | PR | 14-001 | 12-018F | PE |  |  | 13-015 | PE |  |  |  |  |  |  |  |  |  |  |  | 10-070 | 11-026 | 12-029F | 12-035F | 12-026 |  |  |  |  |  | 4288.47 | OB-2 |
| 2365050 |  | Insertable Dump Component Testing |  | 19d | 2013-09-03 A | 2013-09-23 A | 2365045 FS-19d | 100% |  | 2013-10-01 | 2013-10-25 |  |  | 8/5 M-F w/JLAB Holidays ReBaseline | ELEC TECH [32 h] | 1,503.68 | 1,457.28 | 2365050 |  |  |  |  | 0 | GARZA O | 1 | 1 | H | MIKE S |  |  |  | PR | 14-001 | 12-018F | PE |  |  | 13-015 |  |  |  |  |  |  |  |  |  |  |  |  | 10-070 | 11-026 | 12-029F | 12-035F | 12-026 |  |  |  |  |  | 1503.68 |  |
| 2365055 |  | Insertable Dump Sys Implementn |  | 19d | 2013-09-03 A | 2013-09-23 A | 2365050 FS-19d | 100% |  | 2013-10-01 | 2013-10-25 |  |  | 8/5 M-F w/JLAB Holidays ReBaseline | ELEC TECH [24 h] | 1,127.76 | 1,092.96 | 2365055 |  |  |  |  | 0 | GARZA O | 1 | 1 | H | MIKE S |  |  | EV | PR | 14-001 | 12-018F | PE |  |  | 13-015 | PE |  |  |  |  |  |  |  |  |  |  |  | 10-070 | 11-026 | 12-029F | 12-035F | 12-026 |  |  | 08-016 | 09-012 |  | 1127.76 |  |
| 2365060 |  | Insertable Dump Software Implementn & Cmmssng |  | 19d | 2013-09-03 A | 2013-09-23 A | 23458040 FS-30d, 2365055 FS-19d, 23458040a FS-30d | 100% |  | 2013-10-01 | 2013-10-25 |  |  | 8/5 M-F w/JLAB Holidays ReBaseline | ELEC TECH; ELEC ENG; COMP SCIENT |  |  | 2365060 |  |  |  |  | 0 | GARZA O | 1 | 1 | Z | MIKE S |  |  |  | PR |  | 12-018F | PE |  |  | 13-015 |  |  |  |  |  |  |  |  |  |  |  |  | 10-070 | 11-026 | 12-029F | 12-035F | 12-026 |  |  |  |  |  |  |  |
| 2365913LOE |  | FY13 Mngmnt Effort for Dump |  | 20d | 2013-09-03 A | 2013-09-30 A | 9-130M FS+228d | 100% |  | 2013-10-01 | 2013-10-28 |  |  | 8/5 M-F w/JLAB Holidays ReBaseline | SCIENTIST [2.68 h] | 201.48 | 195.26 | 2365913LOE |  |  |  |  | 0 | GARZA O | 1 | 1 | E | MIKE S |  |  |  | PR |  |  | PE |  |  | 13-015 |  |  |  |  |  | 100 | 100 |  |  |  |  |  |  |  |  |  |  |  |  |  |  |  | 195.2648 |  |
| 2365014 |  | HD Dump Sys Prcrmnts |  | 19d | 2013-09-16 A | 2013-10-21 A | 9-140M | 100% |  | 2013-10-01 | 2013-10-25 |  |  | 8/5 M-F w/JLAB Holidays ReBaseline | PROCUREMENT<$50K 60; ELEC TECH [32 h] | 7,695.08 | 1,494.05 | 2365014 | 0 | 6191.4 | 619140 | 100 | 6925.572 | GARZA O | 1 | 1 | D | MIKE S |  |  | EV | PR | 14-001 | 12-018F | PE |  |  | 13-015 |  |  |  |  |  |  |  |  |  |  |  |  | 10-070 | 11-026 | 12-029F | 12-035F |  |  |  |  |  |  | 769.508 | OB-2 |
| 2365065M |  | Insertable Dump Comp | milestone | 0d | 2013-09-23 A | 2013-09-23 A | 2365060 | 100% |  | 2013-10-25 | 2013-10-25 |  |  | 8/5 M-F w/JLAB Holidays ReBaseline |  |  |  | 2365065M |  |  |  |  | 0 | GARZA O | 1 | 1 | M | MIKE S |  |  |  | PR |  | 12-018F |  |  |  | 13-015 |  | 6 |  |  |  |  |  |  |  |  |  |  | 10-070 | 11-026 | 12-029F | 12-035F | 12-026 |  |  |  |  |  |  |  |
| 2365015 |  | HD Dump Sys Fab & Assy |  | 19d | 2013-10-01 A | 2013-11-27 | 2365014 FS-19d | 50% | 19d | 2013-11-01 | 2013-11-27 | 37d | 0d | 8/5 M-F w/JLAB Holidays ReBaseline | PROCUREMENT<$50K 60; SUPPLIES & MATERIALS; ELEC TECH [160 h] | 10,536.73 | 4,117.22 | 2365015 | 1251.19 | 1251.19 | 125119 | 100 | 5268.365 | GARZA O | 1 | 1 | H | MIKE S |  |  | EV | PR | 14-001 | 12-018F | PE |  |  | 13-015 | PE |  |  |  |  |  |  |  |  |  |  |  | 10-070 | 11-026 | 12-029F | 12-035F |  |  |  |  |  |  |  | OB-2 |
| 2365020 |  | HD Dump Component Testing |  | 19d | 2013-11-01 | 2013-11-27 | 2365015 FS-19d |  |  |  |  | 37d | 0d | 8/5 M-F w/JLAB Holidays ReBaseline | ELEC TECH [84 h]; COMP SCIENT [28 h] | 5,903.52 |  | 2365020 |  |  |  |  | 0 | GARZA O | 1 | 1 | H | MIKE S |  |  |  | PR | 14-001 | 12-018F | PE |  |  | 13-015 |  |  |  |  |  |  |  |  |  |  |  |  | 10-070 | 11-026 | 12-029F | 12-035F | 12-026 |  |  |  |  |  |  |  |
| 2365025 |  | HD Dump Sys Implementn |  | 54d | 2013-11-01 | 2014-01-30 | 2365020 FS-19d, 23458045 FS-47d, 23458045a FS-47d |  |  |  |  | 37d | 0d | 8/5 M-F w/JLAB Holidays ReBaseline | PLABOR; ELEC TECH [112 h]; ELEC DES [28 h]; PROCUREMENT<$50K 60 | 11,748.95 |  | 2365025 | 1744.19 | 0 | 0 | 100 | 0 | GARZA O | 1 | 1 | S | MIKE S |  |  | EV | PR | 14-001 | 12-018F | PE |  |  | 13-015 | PE |  |  |  |  |  |  |  |  |  |  |  | 10-070 | 11-026 | 12-029F | 12-035F | 12-026 |  |  | 08-016 | 09-012 |  |  |  |
| 2365030 |  | HD Dump Software Implementn & Cmmssng |  | 55d | 2013-11-21 | 2014-02-20 | 2365025 FS-40d |  |  |  |  | 37d | 0d | 8/5 M-F w/JLAB Holidays ReBaseline | COMP SCIENT [80 h]; ELEC ENG [40 h] | 8,594.8 |  | 2365030 |  |  |  |  | 0 | GARZA O | 1 | 1 | S | MIKE S |  |  |  | PR | 14-001 | 12-018F | PE |  |  | 13-015 |  |  |  |  |  |  |  |  |  |  |  |  | 10-070 | 11-026 | 12-029F | 12-035F | 12-026 |  |  |  |  |  |  |  |
| 2365035M |  | HD Dump Comp | milestone | 0d | 2014-02-20 | 2014-02-20 | 2365030 |  |  |  |  | 37d | 0d | 8/5 M-F w/JLAB Holidays ReBaseline |  |  |  | 2365035M |  |  |  |  | 0 | GARZA O | 1 | 1 | M | MIKE S |  |  |  | PR |  | 12-018F |  |  |  | 13-015 |  | 6 |  |  |  |  |  |  |  |  |  |  | 10-070 | 11-026 | 12-029F | 12-035F | 12-026 |  |  |  |  |  |  |  |

Notes:
- 23643150: Steps: Hall A PSS Equip (ESTop, R/S, Message Disp.); Hall B PSS Equip (ESTop, R/S, Message Disp.); Hall C PSS Equip (ESTop, R/S, Message Disp.); Counting House PSS Equip / BOE NOTES: Based on extrapolation of similar work in support of 6GeV experimental program.
- 23643205: Entry Criteria: Ext Pred: BOD Tagger Bldg, Hall / D, Tunnel Ext / Steps: Install Hall D PA Equipment; Install Tagger PA Equipment; Compelte Wire and Cable Interconnects; Tie-in to MCC PA System / BOE NOTES: Judgment based on knowledge and experience with PA systems as well as informal consultation with vendor experts.
- 23643280: Steps: Tag DB - EPICS Records; Install SW for PSS; Test / BOE NOTES: Judgment based on experience of other labs, and internal experience developing interface for ODH systems.
- 23643070: Entry Criteria: Ext Pred: / Magnets Installed / Steps: Finalize Rack Dwgs; Install PLC Components; Install and Cable Transducers; Install BELS Interface; Program BTM; HW Checkout
- 23643102: Steps: Update EPCIS Software; Update Stopper Control Screen; Test with relay module; Test with Stoppers / BOE NOTES: Materials Prices volatile
- 23643160: Steps: Program Development; Bench Test; Acceptance Test / BOE NOTES: Based on experience designing and implementing systems for SLAC. JLab configuration is different enough to warrant EJ vs. PE.
- 23643070a: Entry Criteria: Ext Pred: / Magnets Installed / Steps: Finalize Specifications; Deliver Tag Database; Create Application; Bench Test; Field Test
- 23643165: Steps: Verify Field I/O; Load Program/Clear Errors; Test Standard Functions; Test Fail-Safe Functions; Test Integrated System
- 1365025: Entry Criteria: Ext Pred: Beamline installed, / vacuum
- 1365055: Entry Criteria: Ext Pred: IOC, network, beamine / installed, vacuum
- 1365030: Entry Criteria: Ext Pred: Beam
- 1365060: Entry Criteria: Ext Pred: Beam
- 2365055: Entry Criteria: Ext Pred: IOC, network, beamine / installed, vacuum
- 2365060: Entry Criteria: Ext Pred: Beam
- 2365025: Entry Criteria: Ext Pred: Beamline installed, / vacuum
- 2365030: Entry Criteria: Ext Pred: Beam

| ID | WBS | Activity | Type | Duration | Start | Finish | Predecessors | Complete | Remaining | Planned start | Planned finish | Total float | Free float | Calendar | Resources | Cost | Actual cost | LOE Divider | LOE Multiplier | Calculated Remaining Total Cost | MONTHLY EV COST | RESP - Responsibility | STRT%COMP for CM EVM | FNSH%COMP for CM EVM | EVMS Reporting Codes | CAM RESPONSIBLE | CR 08-058 | Remaining Material Cost Based on % Compl | Claimed Material Cost Based on % Complet | Initial Claimed Material Calc | Claimed Material Divider | CR 10-031 | CR 10-070 | Activities with Steps | Installation | CR 12-001 | LOE % Pre Calc | LOE % | CR 10-064 | CR 10-066 | Milestone Level | CR 11-026 | CR 12-018 | CR 12-029 | CR 12-035 | MARCH!!! | OPC Allison | CR 12-053 | CR 13-003 | ReBaseline Actuals Adjustment | Original Activity ID Rebaseline | PRIOR MONTH EV COST | BOE Labor | CR 13-015 | Post Rebaseline |
| --- | --- | --- | --- | --- | --- | --- | --- | --- | --- | --- | --- | --- | --- | --- | --- | --- | --- | --- | --- | --- | --- | --- | --- | --- | --- | --- | --- | --- | --- | --- | --- | --- | --- | --- | --- | --- | --- | --- | --- | --- | --- | --- | --- | --- | --- | --- | --- | --- | --- | --- | --- | --- | --- | --- | --- |
|  | 6 | **1.3.6.6 VACUUM CONTROLS** |  |  | 2009-01-02 | 2013-11-27 |  |  |  |  |  |  |  |  |  |  |  |  |  |  |  |  |  |  |  |  |  |  |  |  |  |  |  |  |  |  |  |  |  |  |  |  |  |  |  |  |  |  |  |  |  |  |  |  |  |
| 1366909LOE |  | FY09 Mngmnt Effort for SRFand ARC Vac Controls |  | 189d | 2009-01-02 A | 2009-09-30 A | 1366909LOEX | 100% |  |  |  |  |  |  | SR STAFF [3.05 h] | 313.66 | 313.66 | 100 | 100 | 0 | 313.66117 | GARZA O | 1 | 1 | E | MIKE S | 08-058 |  |  |  |  |  |  |  |  |  |  |  |  |  |  |  |  |  |  |  |  |  |  |  |  |  |  |  |  |
| 1366910LOE |  | FY10 Mngmnt Effort for SRFand ARC Vac Controls |  | 248d | 2009-10-01 A | 2010-09-30 A | 1366909LOE | 100% |  |  |  |  |  |  | SR STAFF [4 h] | 424.48 | 424.48 | 100 | 100 | 0 | 424.48 | GARZA O | 1 | 1 | E | MIKE S |  |  |  |  |  |  |  |  |  |  |  |  |  |  |  |  |  |  |  |  |  |  |  |  |  |  |  |  |  |
| 1366014 |  | SRF Vac Controls Sys Prcrmnts |  | 198d | 2010-05-03 A | 2011-02-21 A | 9-100M FS+142d, 12166035 | 100% |  | 2010-05-03 | 2011-02-18 |  |  |  | ELEC TECH [160 h]; PROCUREMENT<$50K 60; ELEC ENG [160 h] | 242,741.17 | 17,490.19 |  |  | 0 | 242486.18476 | GARZA O | 1 | 1 | D | MIKE S |  | 0 | 225250.98476 | 22525098.476 | 100 | 10-031 | 10-070 |  |  |  |  |  |  |  |  |  |  |  |  |  |  |  |  |  |  |  |  |  |  |
| 1366015 |  | SRF Vac Controls Hardware Fab/Assy/Configuration |  | 170d | 2010-08-16 A | 2011-04-25 A | 1366014 FS-60d, 9-110M FS-20d | 100% |  |  |  |  |  |  | ELEC ENG [200 h]; ELEC TECH [400 h]; SUPPLIES & MATERIALS; TRAVEL; PROCUREMENT<$50K 60; ELEC DES [80 h] | 119,359.81 | 34,492.14 |  |  | 0 | 119567.67 | GARZA O | 1 | 1 | D | MIKE S |  | 0 | 79368.56 | 7936856 | 100 | 10-031 | 10-070 |  |  |  |  |  |  |  |  |  |  |  |  |  |  |  |  |  |  |  |  |  |  |
| 1366020 |  | SRF Vac Controls Sys Installtn Labor FY11 |  | 233d | 2010-08-16 A | 2011-07-25 A | 1362025 FS-265d, 1366015 FS-180d | 100% |  |  |  |  |  |  | ELEC TECH [433.23 h]; ELEC DES [54.15 h] | 21,087.31 | 21,087.31 |  |  | 0 | 21179.8896 | GARZA O | 1 | 1 | S | MIKE S |  |  |  |  |  | 10-031 | 10-070 | ST | Install | 12-001 |  |  |  |  |  |  |  |  |  |  |  |  |  |  |  |  |  |  |  |
| 1366020a |  | SRF Vac Controls Sys Installtn Labor FY12 |  | 233d | 2010-08-16 A | 2011-07-25 A | 1366020 | 100% |  |  |  |  |  |  | ELEC DES [25.85 h]; ELEC TECH [206.77 h] | 10,064.73 | 10,064.73 |  |  | 0 | 10430.4436 | GARZA O | 1 | 1 | S | MIKE S |  |  |  |  |  | 10-031 | 10-070 | ST |  | 12-001 |  |  |  |  |  |  |  |  |  |  |  |  |  |  |  |  |  |  |  |
| 1366020b |  | SRF Vac Controls Sys Installtn Labor Procurement |  | 233d | 2010-08-16 A | 2011-07-25 A | 1362025 FS-265d, 1366015 FS-180d | 100% |  |  |  |  |  |  | PROCUREMENT<$50K 60 NO ESCALATION FY12 | 28,345.91 |  |  |  | 0 | 28345.91 | GARZA O | 1 | 1 | S | MIKE S |  | 0 | 28345.91 | 2834591 | 100 | 10-031 | 10-070 | ST |  | 12-001 |  |  |  |  |  |  |  |  |  |  |  |  |  |  |  |  |  |  |  |
| 1366911LOE |  | FY11 Mngmnt Effort for SRFand ARC Vac Controls |  | 248d | 2010-10-01 A | 2011-09-30 A | 1366910LOE | 100% |  |  |  |  |  |  | SR STAFF [36 h] | 3,942.36 | 3,942.36 | 100 | 100 | 0 | 3942.36 | GARZA O | 1 | 1 | E | MIKE S |  |  |  |  |  |  |  |  |  |  | 8.46774193 | 91.53225806 |  |  |  |  |  |  |  |  |  |  |  |  |  |  |  |  |  |
| 1366025 |  | SRF Vac Controls Software Implementn & Sys Testing FY11 |  | 103d | 2011-03-01 A | 2011-07-25 A | 1366020b FS-165d, 1366020 FS-165d, 1366020a FS-165d | 100% |  |  |  |  |  |  | COMP SCIENT [221.33 h]; ELEC ENG [66.4 h]; ELEC TECH [66.4 h] | 21,454.73 | 21,454.73 |  |  | 0 | 21454.7347 | GARZA O | 1 | 1 | H | MIKE S |  |  |  |  |  | 10-031 | 10-070 |  |  | 12-001 |  |  | 10-064 | 10-066 |  |  |  |  |  |  |  |  |  |  |  |  |  |  |  |
| 1366025a |  | SRF Vac Controls Software Implementn & Sys Testing FY12 |  | 103d | 2011-03-01 A | 2011-07-25 A | 1366025 | 100% |  |  |  |  |  |  | COMP SCIENT [178.67 h]; ELEC ENG [53.6 h]; ELEC TECH [53.6 h] | 17,319.27 | 17,319.27 |  |  | 0 | 17871.7094 | GARZA O | 1 | 1 | H | MIKE S |  |  |  |  |  | 10-031 | 10-070 |  |  | 12-001 |  |  | 10-064 | 10-066 |  |  |  |  |  |  |  |  |  |  |  |  |  |  |  |
| 1366030M |  | SRF Vacuum Controls Sys Comp | milestone | 0d | 2011-07-25 A | 2011-07-25 A | 1366025a | 100% |  | 2011-08-01 | 2011-08-01 |  |  |  |  |  |  |  |  |  | 0 | GARZA O | 1 | 1 | M | MIKE S |  |  |  |  |  | 10-031 | 10-070 |  |  |  |  |  | 10-064 | 10-066 | 6 |  |  |  |  |  |  |  |  |  |  |  |  |  |  |
| 1366912LOE |  | FY12 Mngmnt Effort for SRFand ARC Vac Controls |  | 247d | 2011-10-03 A | 2012-09-28 A | 1366911LOE | 100% |  |  |  |  |  |  | SR STAFF [36 h] | 4,068 | 4,068 | 100 | 100 | 0 | 4068 | GARZA O | 1 | 1 | E | MIKE S |  |  |  |  |  |  |  |  |  |  | 7.69230769 | 92.3076923 |  |  |  |  |  |  |  |  |  |  |  |  |  |  |  |  |  |
| 1366035 |  | ARC Vac Controls Sys Prcrmnts |  | 53d | 2012-02-01 A | 2012-04-16 A | 12166035, 9-120M FS+80d | 100% |  |  |  |  |  |  | ELEC TECH [120 h]; PROCUREMENT<$50K 60; ELEC ENG [40 h] | 81,828.37 | 8,118 |  |  | 0 | 81828.37 | GARZA O | 1 | 1 | H | MIKE S |  | 0 | 73710.37 | 7371037 | 100 |  | 10-070 |  |  |  |  |  |  |  |  | 11-026 | 12-018F | 12-029F | 12-035F |  |  |  |  |  |  |  |  |  |  |
| 1366040 |  | ARC Vac Controls Hardware Fab/Assy/Configuration |  | 173d | 2012-04-09 A | 2013-01-31 A | 1366035 | 100% |  | 2012-04-09 | 2012-12-12 |  |  |  | TRAVEL; ELEC DES [40 h]; PROCUREMENT<$50K 60; ELEC TECH [320 h]; SUPPLIES & MATERIALS | 39,155.9 | 16,346.19 |  |  | 0 | 39003.91 | GARZA O | 1 | 1 | H | MIKE S |  | 0 | 17550.09 | 1755009 | 100 |  | 10-070 |  |  |  |  |  |  |  |  | 11-026 | 12-018F | 12-029F | 12-035F | XX |  |  |  |  |  |  |  |  |  |
| 1366045 |  | ARC Vac Controls Sys Installtn FY12 |  | 134d | 2012-06-05 A | 2013-01-31 A | 2-02M, 1366040 FS-30d | 100% |  | 2012-06-05 | 2012-12-12 |  |  |  | ELEC TECH [164.44 h]; ELEC DES [32.89 h]; PLABOR | 11,177.4 | 9,061.81 |  |  | 0 | 11068.1011 | GARZA O | 1 | 1 | H | MIKE S |  |  |  |  |  |  | 10-070 |  | Install |  |  |  |  |  |  | 11-026 | 12-018F | 12-029F | 12-035F | XX | OPC A | 12-053 |  |  |  |  |  |  |  |
| 1366045a |  | ARC Vac Controls Sys Installtn FY13 |  | 134d | 2012-06-05 A | 2013-08-30 A | 1366045 FS-30d | 100% |  | 2012-06-05 | 2012-12-12 |  |  |  | PLABOR; ELEC TECH [35.56 h]; ELEC DES [7.11 h] | 2,431.54 | 1,973.54 |  |  | 1234.8428 | 2469.6856 | GARZA O | 1 | 1 | H | MIKE S |  |  |  |  |  |  | 10-070 |  |  |  |  |  |  |  |  | 11-026 | 12-018F | 12-029F | 12-035F | XX |  | 12-053 |  |  |  |  |  |  |  |
| 1366045b |  | ARC Vac Controls Sys Installtn Procurement |  | 134d | 2012-06-05 A | 2013-01-31 A | 2-02M, 1366040 FS-30d | 100% |  | 2012-06-05 | 2012-12-12 |  |  |  | PROCUREMENT<$50K 60 NO ESCALATION FY13 | 17,550.09 |  |  |  | 0 | 17550.09 | GARZA O | 1 | 1 | H | MIKE S |  | 0 | 17550.09 | 1755009 | 100 |  | 10-070 |  |  |  |  |  |  |  |  | 11-026 | 12-018F | 12-029F | 12-035F | XX |  | 12-053 |  |  |  |  |  |  |  |
| 1366047 |  | ARC Vac Controls Sys Installtn Additonal effort per 2012 ETC |  | 51d | 2012-10-01 A | 2013-08-30 A | 9-130M | 100% |  | 2012-10-01 | 2012-12-12 |  |  |  | ELEC TECH [480 h]; ELEC ENG [88 h]; PROCUREMENT<$50K 60 | 40,266.48 | 28,266.48 |  |  | 20133.24 | 40266.48 | GARZA O | 1 | 1 | H | MIKE S |  | 0 | 12000 | 1200000 | 100 |  | 10-070 |  |  |  |  |  |  |  |  | 11-026 | 12-018F | 12-029F | 12-035F | XX |  | 12-053 | 13-003 |  |  |  |  |  |  |
| 1366050a |  | ARC Vac Controls Software Implementn & Sys Testing FY13 |  | 23d | 2013-01-14 A | 2013-08-30 A | 1366050 FS-20d | 100% |  | 2013-04-08 | 2013-05-08 |  |  |  | ELEC TECH [26.29 h]; COMP SCIENT [52.57 h] | 4,756.76 | 4,756.76 |  |  | 2378.38065 | 4756.7613 | GARZA O | 1 | 1 | H | MIKE S |  |  |  |  |  |  | 10-070 |  |  |  |  |  |  |  |  | 11-026 | 12-018F | 12-029F | 12-035F |  |  | 12-053 |  |  |  |  |  |  |  |
| 1366050 |  | ARC Vac Controls Software Implementn & Sys Testing FY12 |  | 37d | 2013-01-21 A | 2013-01-31 A | 1362025, 1366045b FS-30d, 1366045a FS-30d, 1366047 FS-40d, 1366045 FS-30d | 100% |  | 2013-02-13 | 2013-04-05 |  |  |  | ELEC TECH [53.71 h]; COMP SCIENT [107.43 h] | 9,720.04 | 9,720.04 |  |  | 0 | 9419.7789 | GARZA O | 1 | 1 | H | MIKE S |  |  |  |  |  |  | 10-070 |  |  |  |  |  |  |  |  | 11-026 | 12-018F | 12-029F | 12-035F |  | OPC A | 12-053 |  |  |  |  |  |  |  |
| 1366950 |  | Re-Baseline Actuals Adjustment |  | 1d | 2013-08-30 A | 2013-08-30 A |  | 100% |  | 2013-09-03 | 2013-09-03 |  |  |  | PROCUREMENT>$50K 69 NO ESCALATION | 222,962.04 |  |  |  |  | 222962.04 |  |  |  |  |  |  | 0 | 222962.04 | 22296204 | 100 |  |  |  |  |  |  |  |  |  |  |  |  |  |  |  |  |  |  | ADJ |  |  |  |  |  |
| 1366055M |  | ARC Vacuum Controls Sys Comp | milestone | 0d | 2013-08-30 A | 2013-08-30 A | 1366050a | 100% |  | 2013-09-17 | 2013-09-17 |  |  |  |  |  |  |  |  |  | 0 | GARZA O | 1 | 1 | M | MIKE S |  |  |  |  |  |  | 10-070 |  |  |  |  |  |  |  | 6 | 11-026 | 12-018F | 12-029F | 12-035F |  | OPC A |  |  |  |  |  |  |  |  |
| 2366050a |  | ARC Vac Controls Software Implementn |  | 19d | 2013-09-03 A | 2013-11-27 | 9-130M FS+228d | 50% | 19d | 2013-10-01 | 2013-10-25 | 87d | 0d | 8/5 M-F w/JLAB Holidays ReBaseline | COMP SCIENT [88 h] | 6,148.56 | 3,055.63 |  |  |  | 0 | GARZA O | 1 | 1 | H | MIKE S |  |  |  |  |  |  | 10-070 |  |  |  |  |  |  |  |  | 11-026 | 12-018F | 12-029F | 12-035F |  |  | 12-053 |  |  | 2366050a | 2979.24 | PE | 13-015 | PR |
| 2366051 |  | ARC Vac Controls Hardware Implementation & Testing |  | 19d | 2013-09-03 A | 2013-11-27 | 2366050a FS-19d |  | 19d | 2013-10-01 | 2013-10-25 | 87d | 0d | 8/5 M-F w/JLAB Holidays ReBaseline | ELEC TECH [240 h] | 11,277.6 | 5,604.92 |  |  |  | 0 | GARZA O | 1 | 1 | S | MIKE S |  |  |  |  |  |  | 10-070 | ST |  |  |  |  |  |  |  | 11-026 | 12-018F | 12-029F | 12-035F |  |  | 12-053 |  |  | 2366051 |  | PE | 13-015 | PR |
| 2366055M |  | ARC Vacuum Controls Sys Comp | milestone | 0d | 2013-11-27 | 2013-11-27 | 2366051, 2366050a |  |  |  |  | 87d | 50d | 8/5 M-F w/JLAB Holidays ReBaseline |  |  |  |  |  |  | 0 | GARZA O | 1 | 1 | M | MIKE S |  |  |  |  |  |  | 10-070 |  |  |  |  |  |  |  | 6 | 11-026 | 12-018F | 12-029F | 12-035F |  |  |  |  |  | 2366055M |  |  | 13-015 | PR |

Notes:
- 1366020: Entry Criteria: Ext Pred: New CMs installed, / beamliine, IOCs, network / Steps: Cables Installed (done); Racks Installed (done); Racks Populated (done)
- 1366020a: Entry Criteria: Ext Pred: New CMs installed, / beamliine, IOCs, network / Steps: Cables Installed (done); Racks Installed (done); Racks Populated (done)
- 1366020b: Entry Criteria: Ext Pred: New CMs installed, / beamliine, IOCs, network / Steps: Cables Installed (done); Racks Installed (done); Racks Populated (done)
- 1366050a: Entry Criteria: Ext Pred: Beamline, IOCs, / network
- 1366050: Entry Criteria: Ext Pred: Beamline, IOCs, / network
- 2366050a: Entry Criteria: Ext Pred: Beamline, IOCs, / network
- 2366051: Entry Criteria: Ext Pred: Beamline, IOCs, / network / Steps: ARC 10 Testing; Hall D BL Testing

| ID | WBS | Activity | Duration | Start | Finish | Predecessors | Complete | Remaining | Planned start | Planned finish | Total float | Free float | Calendar | Resources | Cost | Actual cost | Remaining Material Cost Based on % Compl | Claimed Material Cost Based on % Complet | Initial Claimed Material Calc | Claimed Material Divider | Calculated Remaining Total Cost | MONTHLY EV COST | RESP - Responsibility | STRT%COMP for CM EVM | FNSH%COMP for CM EVM | EVMS Reporting Codes | CAM RESPONSIBLE | CR 10-070 | In Progress Procurements | Installation | OPC Allison | CR 08-016 | CR 09-012 | CR 10-065 | CR 12-035 | CR 12-053 | MARCH!!! | CR 10-031 | CR 13-003 | ReBaseline Actuals Adjustment | Original Activity ID Rebaseline | Activities with Steps | BOE Labor | CR 13-015 | Post Rebaseline | CR 14-001 | PRIOR MONTH EV COST | BOE Procurement | Obligated Prior to Rebaseline |
| --- | --- | --- | --- | --- | --- | --- | --- | --- | --- | --- | --- | --- | --- | --- | --- | --- | --- | --- | --- | --- | --- | --- | --- | --- | --- | --- | --- | --- | --- | --- | --- | --- | --- | --- | --- | --- | --- | --- | --- | --- | --- | --- | --- | --- | --- | --- | --- | --- | --- |
|  | 7 | **1.3.6.7 MAGNET INSTRUMENTATION** |  | 2011-12-05 | 2014-02-07 |  |  |  |  |  |  |  |  |  |  |  |  |  |  |  |  |  |  |  |  |  |  |  |  |  |  |  |  |  |  |  |  |  |  |  |  |  |  |  |  |  |  |  |  |
| 1367005 |  | Mag Instrmenttn Prcrmnts | 254d | 2011-12-05 A | 2012-12-17 A | 12167028, 9-120M FS+60d | 100% |  | 2011-12-05 | 2012-12-11 |  |  |  | PROCUREMENT<$50K 60; ELEC TECH [80 h] | 80,772.99 | 3,554.01 | 0 | 77220.39 | 7722039 | 100 | 0 | 80750.79 | GARZA O | 1 | 1 | D | MIKE S | 10-070 | Split |  |  |  |  |  |  |  |  |  |  |  |  |  |  |  |  |  |  |  |  |
| 1367010 |  | Mag Instrmenttn Fab & Assy | 133d | 2012-06-05 A | 2012-12-17 A | 1367005 FS-25d | 100% |  | 2012-06-05 | 2012-12-11 |  |  |  | ELEC TECH [360 h]; SUPPLIES & MATERIALS; TRAVEL; ELEC DES [40 h]; PROCUREMENT<$50K 60 | 55,562.42 | 18,132.66 | 0 | 28080.14 | 2808014 | 100 | 0 | 55347.38 | GARZA O | 1 | 1 | H | MIKE S | 10-070 |  | Install | OPC A |  |  |  |  |  |  |  |  |  |  |  |  |  |  |  |  |  |  |
| 1367015 |  | Mag Instrmenttn Testing | 133d | 2012-06-05 A | 2012-12-17 A | 1367010 FS-100d, 9-120M | 100% |  | 2012-06-05 | 2012-12-11 |  |  |  | COMP SCIENT [160 h]; ELEC TECH [160 h]; PROCUREMENT<$50K 60 | 22,450.54 | 17,780.73 | 0 | 4680.02 | 468002 | 100 | 0 | 22240.02 | GARZA O | 1 | 1 | H | MIKE S | 10-070 |  |  | OPC A |  |  |  |  |  |  |  |  |  |  |  |  |  |  |  |  |  |  |
| 1367020 |  | Mag Instrmenttn Implementn FY12 | 58d | 2012-10-08 A | 2013-08-30 A | 1362025 FS-115d, 1367015 FS-40d | 100% |  | 2012-10-08 | 2013-01-07 |  |  |  | ELEC DES [19 h]; ELEC TECH [247 h]; SUPPLIES & MATERIALS | 13,389.07 | 12,238.66 |  |  |  |  | 6505.105 | 13010.21 | GARZA O | 1 | 1 | H | MIKE S | 10-070 |  |  | OPC A | 08-016 | 09-012 | 10-065 | 12-035 | 12-053 | XX |  |  |  |  |  |  |  |  |  |  |  |  |
| 1367020a |  | Mag Instrmenttn Implementn FY13 | 58d | 2012-10-08 A | 2013-08-12 A | 1367020 FS-60d | 100% |  | 2012-10-08 | 2013-01-07 |  |  |  | ELEC DES [21 h]; ELEC TECH [273 h]; SUPPLIES & MATERIALS | 14,839 | 13,526.94 |  |  |  |  | 7419.5 | 14839 | GARZA O | 1 | 1 | H | MIKE S | 10-070 |  |  |  | 08-016 | 09-012 | 10-065 | 12-035 | 12-053 | XX |  |  |  |  |  |  |  |  |  |  |  |  |
| 1367020b |  | Mag Instrmenttn Implementn Procurement | 133d | 2012-11-12 A | 2013-08-30 A | 1367015 FS-20d, 1362025 FS-115d | 100% |  | 2012-11-12 | 2013-05-30 |  |  |  | PROCUREMENT<$50K 60 NO ESCALATION FY13 | 14,040.06 |  | 0 | 14040.06 | 1404006 | 100 | 7020.03 | 14040.06 | GARZA O | 1 | 1 | H | MIKE S | 10-070 |  |  |  | 08-016 | 09-012 | 10-065 | 12-035 | 12-053 |  |  |  |  |  |  |  |  |  |  |  |  |  |
| 1367030 |  | Magnet Communication New I/O IP design - Labor | 110d | 2012-11-12 A | 2013-08-30 A | 9-130M | 100% |  | 2012-11-12 | 2013-04-26 |  |  |  | ELEC TECH [80 h]; ELEC ENG [172 h] | 16,166.52 | 16,166.52 |  |  |  |  | 8083.26 | 16166.52 | GARZA O | 1 | 1 | H | MIKE S | 10-070 |  |  |  |  |  | 10-065 | 12-035 | 12-053 |  | 10-031 | 13-003 |  |  |  |  |  |  |  |  |  |  |
| 1367025 |  | Mag Instrmenttn Software Implementn & Cmmssng FY12 | 67d | 2013-03-04 A | 2013-08-30 A | 1367020b FS-130d, 1362025, 1367020a FS-130d, 1367020 FS-130d | 100% |  | 2013-04-01 | 2013-07-03 |  |  |  | ELEC TECH [57.43 h]; COMP SCIENT [153.14 h] | 12,984.47 | 12,984.47 |  |  |  |  | 6291.71635 | 12583.4327 | GARZA O | 1 | 1 | H | MIKE S | 10-070 |  |  | OPC A |  |  | 10-065 | 12-035 | 12-053 |  | 10-031 |  |  |  |  |  |  |  |  |  |  |  |
| 1367025a |  | Mag Instrmenttn Software Implementn & Cmmssng FY13 | 73d | 2013-03-04 A | 2013-08-30 A | 1367025 FS-60d | 100% |  | 2013-07-05 | 2013-10-16 |  |  |  | ELEC TECH [62.57 h]; COMP SCIENT [166.86 h] | 14,221.69 | 14,147.53 |  |  |  |  | 7073.7642 | 14147.5284 | GARZA O | 1 | 1 | H | MIKE S | 10-070 |  |  |  |  |  | 10-065 | 12-035 | 12-053 |  | 10-031 |  |  |  |  |  |  |  |  |  |  |  |
| 1367035 |  | Magnet Communication New I/O IP design - Proc. | 20d | 2013-04-01 A | 2013-08-30 A | 1367030 FS-41d | 100% |  | 2013-05-01 | 2013-05-29 |  |  |  | ELEC TECH [40 h]; ELEC ENG [28 h]; PROCUREMENT<$50K 60 | 14,860.28 | 3,860.28 | 0 | 11000 | 1100000 | 100 | 5944.112 | 14860.28 | GARZA O | 1 | 1 | D | MIKE S | 10-070 |  |  |  |  |  | 10-065 | 12-035 | 12-053 |  | 10-031 | 13-003 |  |  |  |  |  |  |  |  |  |  |
| 1367040 |  | Magnet Communication New I/O IP Fabrication | 40d | 2013-04-08 A | 2013-08-30 A | 1367035 FS-30d | 100% |  | 2013-07-02 | 2013-08-27 |  |  |  | ELEC TECH [240 h]; PROCUREMENT<$50K 60 | 14,929.6 | 10,929.6 | 0 | 4000 | 400000 | 100 | 7464.8 | 14929.6 | GARZA O | 1 | 1 | H | MIKE S | 10-070 |  |  |  |  |  | 10-065 | 12-035 | 12-053 |  | 10-031 | 13-003 |  |  |  |  |  |  |  |  |  |  |
| 1367045 |  | Magnet Communication New I/O IP Testing | 20d | 2013-06-01 A | 2013-08-30 A | 1367040 FS-18d | 100% |  | 2013-07-01 | 2013-07-29 |  |  |  | ELEC TECH [80 h]; ELEC ENG [28 h] | 5,681.88 | 5,681.88 |  |  |  |  | 2840.94 | 5681.88 | GARZA O | 1 | 1 | H | MIKE S | 10-070 |  |  |  |  |  | 10-065 | 12-035 | 12-053 |  | 10-031 | 13-003 |  |  |  |  |  |  |  |  |  |  |
| 1367050 |  | Magnet Communication New I/O IP Installation | 20d | 2013-07-08 A | 2013-08-30 A | 1367045 FS-25d | 100% |  | 2013-08-29 | 2013-09-26 |  |  |  | ELEC TECH [80 h]; ELEC ENG [28 h] | 5,681.88 | 5,681.88 |  |  |  |  | 5681.88 | 5681.88 | GARZA O | 1 | 1 | H | MIKE S | 10-070 |  |  |  |  |  | 10-065 | 12-035 | 12-053 |  | 10-031 | 13-003 |  |  |  |  |  |  |  |  |  |  |
| 1367055 |  | Magnet Communication New I/O IP Software -Labor | 40d | 2013-07-15 A | 2013-08-30 A | 1367045 FS-25d | 100% |  | 2013-08-29 | 2013-10-24 |  |  |  | ELEC ENG [116 h] | 8,567.06 | 8,445.96 |  |  |  |  | 8445.96 | 8445.96 | GARZA O | 1 | 1 | H | MIKE S | 10-070 |  |  |  |  |  | 10-065 | 12-035 | 12-053 |  | 10-031 | 13-003 |  |  |  |  |  |  |  |  |  |  |
| 1367060 |  | Re-Baseline Actuals Adjustment | 1d | 2013-08-30 A | 2013-08-30 A |  | 100% |  | 2013-09-03 | 2013-09-03 |  |  |  | PROCUREMENT>$50K 69 NO ESCALATION | -99,867.79 |  |  |  |  | 100 |  |  |  |  |  |  |  |  |  |  |  |  |  |  |  |  |  |  |  | ADJ |  |  |  |  |  |  |  |  |  |
| 2367025a |  | Mag Instrmenttn Software Implementn & Cmmssng FY13 | 103d | 2013-09-03 A | 2014-02-07 | 9-130M FS+228d, 23221024ba FS-198d | 70% | 60d | 2013-10-01 | 2014-03-07 | 46d | 9d | 8/5 M-F w/JLAB Holidays ReBaseline | ELEC TECH [9.98 h]; COMP SCIENT [26.63 h] | 2,329.5 | 958.53 |  |  |  |  |  | 1580.2589355 | GARZA O | 1 | 1 | S | MIKE S | 10-070 |  |  |  |  |  | 10-065 | 12-035 | 12-053 |  | 10-031 |  |  | 2367025a | ST | PE | 13-015 | PR |  |  |  |  |
| 2367025aa |  | Mag Instrmenttn Software Implementn & Cmmssng FY14 | 83d | 2013-09-03 A | 2014-02-07 | 2367025a FS-100d | 70% | 60d | 2013-10-01 | 2014-02-07 | 46d | 9d | 8/5 M-F w/JLAB Holidays ReBaseline | ELEC TECH [41.44 h]; COMP SCIENT [110.5 h] | 9,667.97 | 3,978.13 |  |  |  |  |  | 6767.5806618 | GARZA O | 1 | 1 | S | MIKE S | 10-070 |  |  |  |  |  | 10-065 | 12-035 | 12-053 |  | 10-031 |  |  | 2367025a | ST | PE | 13-015 | PR | 14-001 |  |  |  |
| 2367030 |  | Magnet Communication New I/O IP design - Labor FY13 | 52d | 2013-09-03 A | 2013-10-21 A | 9-130M FS+228d | 100% |  | 2013-10-01 | 2013-12-13 |  |  | 8/5 M-F w/JLAB Holidays ReBaseline | ELEC ENG [4.52 h]; ELEC TECH [2.1 h] | 438.22 | 434.03 |  |  |  |  |  | 212.344216 | GARZA O | 1 | 1 | H | MIKE S | 10-070 |  |  |  |  |  | 10-065 | 12-035 | 12-053 |  | 10-031 | 13-003 |  | 2367030 |  | PE | 13-015 | PR |  | 212.344216 |  |  |
| 2367030a |  | Magnet Communication New I/O IP design - Labor FY14 | 32d | 2013-09-03 A | 2013-10-21 A | 2367030 FS-35d | 100% |  | 2013-10-01 | 2013-11-13 |  |  | 8/5 M-F w/JLAB Holidays ReBaseline | ELEC ENG [7.23 h]; ELEC TECH [3.37 h] | 701.67 | 693.8 |  |  |  |  |  | 350.83944 | GARZA O | 1 | 1 | H | MIKE S | 10-070 |  |  |  |  |  | 10-065 | 12-035 | 12-053 |  | 10-031 | 13-003 |  | 2367030 |  | PE | 13-015 | PR | 14-001 | 350.83944 |  |  |
| 2367035 |  | Magnet Communication New I/O IP design - Proc. | 31d | 2013-09-16 A | 2013-11-15 | 2367030 FS-31d, 2367030a FS-31d | 13% | 11d | 2013-10-30 | 2013-12-13 | 141d | 20d | 8/5 M-F w/JLAB Holidays ReBaseline | ELEC ENG [8.4 h]; PROCUREMENT<$50K 60; ELEC TECH [12 h] | 4,600.24 | 893.85 | 2962.5849 | 442.6851 | 44268.51 | 100 |  | 0 | GARZA O | 1 | 1 | D | MIKE S | 10-070 |  |  |  |  |  | 10-065 | 12-035 | 12-053 |  | 10-031 | 13-003 |  | 2367035 |  | PE | 13-015 | PR | 14-001 | 598.03146 | PE | OB-2 |
| 2367040 |  | Magnet Communication New I/O IP Fabrication | 31d | 2013-09-16 A | 2013-11-15 | 2367035 FS-31d | 50% | 11d | 2013-10-02 | 2013-11-13 | 121d | 20d | 8/5 M-F w/JLAB Holidays ReBaseline | PROCUREMENT<$50K 60; ELEC TECH [144 h] | 9,243.12 | 5,061.47 | 1238.28 | 1238.28 | 123828 | 100 |  | 0 | GARZA O | 1 | 1 | H | MIKE S | 10-070 |  |  |  |  |  | 10-065 | 12-035 | 12-053 |  | 10-031 | 13-003 |  | 2367040 |  | PE | 13-015 | PR | 14-001 | 4621.56 | PE | OB-2 |
| 2367045 |  | Magnet Communication New I/O IP Testing | 30d | 2013-09-16 A | 2013-11-15 | 2367040 FS-31d | 50% | 11d | 2013-10-02 | 2013-11-12 | 101d | 20d | 8/5 M-F w/JLAB Holidays ReBaseline | ELEC TECH [64 h]; ELEC ENG [22.4 h] | 4,690.27 | 3,508.37 |  |  |  |  |  | 0 | GARZA O | 1 | 1 | H | MIKE S | 10-070 |  |  |  |  |  | 10-065 | 12-035 | 12-053 |  | 10-031 | 13-003 |  | 2367045 |  | PE | 13-015 | PR | 14-001 | 2345.136 | PE |  |
| 2367050 |  | Magnet Communication New I/O IP Installation | 30d | 2013-09-16 A | 2013-11-18 | 2367045 FS-31d | 50% | 12d | 2013-10-01 | 2013-11-11 | 81d | 68d | 8/5 M-F w/JLAB Holidays ReBaseline | ELEC TECH [64 h]; ELEC ENG [22.4 h] | 4,690.27 | 3,432.1 |  |  |  |  |  | 0 | GARZA O | 1 | 1 | H | MIKE S | 10-070 |  |  |  |  |  | 10-065 | 12-035 | 12-053 |  | 10-031 | 13-003 |  | 2367050 |  | PE | 13-015 | PR | 14-001 | 2345.136 | PE |  |
| 2367055 |  | Magnet Communication New I/O IP Software -Labor | 30d | 2013-09-16 A | 2013-11-18 | 2367045 FS-31d | 50% | 12d | 2013-10-01 | 2013-11-11 | 90d | 28d | 8/5 M-F w/JLAB Holidays ReBaseline | ELEC ENG [92.8 h] | 6,972.06 | 5,101.78 |  |  |  |  |  | 0 | GARZA O | 1 | 1 | H | MIKE S | 10-070 |  |  |  |  |  | 10-065 | 12-035 | 12-053 |  | 10-031 | 13-003 |  | 2367055 |  | PE | 13-015 | PR | 14-001 | 3486.032 |  |  |

Notes:
- 1367020: Entry Criteria: Ext Pred: Corresponding magnets, power supplies and beamline / installed
- 1367020a: Entry Criteria: Ext Pred: Corresponding magnets, power supplies and beamline / installed
- 1367020b: Entry Criteria: Ext Pred: Corresponding magnets, power supplies and beamline / installed
- 1367030: Entry Criteria: Ext Pred: Magnet IOCs and / network installed and useable
- 1367025: Entry Criteria: Ext Pred: Magnet IOCs and / network installed and useable
- 1367025a: Entry Criteria: Ext Pred: Magnet IOCs and / network installed and useable
- 1367035: Entry Criteria: Ext Pred: Magnet IOCs and / network installed and useable
- 1367040: Entry Criteria: Ext Pred: Magnet IOCs and / network installed and useable
- 1367045: Entry Criteria: Ext Pred: Magnet IOCs and / network installed and useable
- 1367050: Entry Criteria: Ext Pred: Magnet IOCs and / network installed and useable
- 1367055: Entry Criteria: Ext Pred: Magnet IOCs and / network installed and useable
- 2367025a: Entry Criteria: Ext Pred: Magnet IOCs and / network installed and useable / Steps: Arc Magnet Instrumentation (done); Hall D Tagger Magnet Instrumentation
- 2367025aa: Entry Criteria: Ext Pred: Magnet IOCs and / network installed and useable / Steps: Arc Magnet Instrumentation (done); Hall D Tagger Magnet Instrumentation
- 2367030: Entry Criteria: Ext Pred: Magnet IOCs and / network installed and useable
- 2367030a: Entry Criteria: Ext Pred: Magnet IOCs and / network installed and useable
- 2367035: Entry Criteria: Ext Pred: Magnet IOCs and / network installed and useable
- 2367040: Entry Criteria: Ext Pred: Magnet IOCs and / network installed and useable
- 2367045: Entry Criteria: Ext Pred: Magnet IOCs and / network installed and useable
- 2367050: Entry Criteria: Ext Pred: Magnet IOCs and / network installed and useable
- 2367055: Entry Criteria: Ext Pred: Magnet IOCs and / network installed and useable

| ID | WBS | Activity | Duration | Start | Finish | Predecessors | Complete | Planned start | Planned finish | LOE Divider | LOE Multiplier | MONTHLY EV COST | RESP - Responsibility | STRT%COMP for CM EVM | FNSH%COMP for CM EVM | CR 07-024 | EVMS Reporting Codes | CAM RESPONSIBLE | CR 09-012 | LOE % | LOE % Pre Calc | CR 11-026 | Installation |
| --- | --- | --- | --- | --- | --- | --- | --- | --- | --- | --- | --- | --- | --- | --- | --- | --- | --- | --- | --- | --- | --- | --- | --- |
|  | 4 | **1.4 CONSTRUCTION UPGRADE HALLS A, B, & C** |  | 2008-10-01 | 2016-05-12 |  |  |  |  |  |  |  |  |  |  |  |  |  |  |  |  |  |  |
|  | 1 | **1.4.1 CONSTRUCTION HALL A** |  | 2008-10-01 | 2013-12-20 |  |  |  |  |  |  |  |  |  |  |  |  |  |  |  |  |  |  |
|  | 1 | **1.4.1.1 MAGNET** |  |  |  |  |  |  |  |  |  |  |  |  |  |  |  |  |  |  |  |  |  |
|  | 1 | **1.4.1.1.1 COMBINED FUNCTION MAGNET** |  |  |  |  |  |  |  |  |  |  |  |  |  |  |  |  |  |  |  |  |  |
|  | 2 | **1.4.1.1.2 CRYOGENIC SYSTEM** |  |  |  |  |  |  |  |  |  |  |  |  |  |  |  |  |  |  |  |  |  |
|  | 3 | **1.4.1.1.3 POWER SUPPLY INFRASTRUCTURE** |  |  |  |  |  |  |  |  |  |  |  |  |  |  |  |  |  |  |  |  |  |
|  | 4 | **1.4.1.1.4 SHIELD HOUSE** |  |  |  |  |  |  |  |  |  |  |  |  |  |  |  |  |  |  |  |  |  |
|  | 5 | **1.4.1.1.5 SUPPORT STRUCTURE & MOTION SYSTEM** |  |  |  |  |  |  |  |  |  |  |  |  |  |  |  |  |  |  |  |  |  |
|  | 6 | **1.4.1.1.6 CONTROL SYSTEM** |  |  |  |  |  |  |  |  |  |  |  |  |  |  |  |  |  |  |  |  |  |
|  | 7 | **1.4.1.1.7 MAD SEPTUM** |  |  |  |  |  |  |  |  |  |  |  |  |  |  |  |  |  |  |  |  |  |
|  | 2 | **1.4.1.2 DETECTOR** |  |  |  |  |  |  |  |  |  |  |  |  |  |  |  |  |  |  |  |  |  |
|  | 1 | **1.4.1.2.1 TRIGGER SYSTEM (Scintillators)** |  |  |  |  |  |  |  |  |  |  |  |  |  |  |  |  |  |  |  |  |  |
|  | 2 | **1.4.1.2.2 TRACKING SYSTEM (Drift Chambers)** |  |  |  |  |  |  |  |  |  |  |  |  |  |  |  |  |  |  |  |  |  |
|  | 3 | **1.4.1.2.3 GAS CERENKOV** |  |  |  |  |  |  |  |  |  |  |  |  |  |  |  |  |  |  |  |  |  |
|  | 4 | **1.4.1.2.4 AEROGEL CERENKOV** |  |  |  |  |  |  |  |  |  |  |  |  |  |  |  |  |  |  |  |  |  |
|  | 5 | **1.4.1.2.5 CALORIMETER** |  |  |  |  |  |  |  |  |  |  |  |  |  |  |  |  |  |  |  |  |  |
|  | 6 | **1.4.1.2.6 FOCAL PLANE POLARIMETER** |  |  |  |  |  |  |  |  |  |  |  |  |  |  |  |  |  |  |  |  |  |
|  | 3 | **1.4.1.3 COMPUTING** |  | 2008-10-01 | 2012-01-30 |  |  |  |  |  |  |  |  |  |  |  |  |  |  |  |  |  |  |
|  | 1 | **1.4.1.3.1 DAQ FOR MAD** |  |  |  |  |  |  |  |  |  |  |  |  |  |  |  |  |  |  |  |  |  |
|  | 2 | **1.4.1.3.2 DAQ UPGRADES FOR HRS** |  | 2008-10-01 | 2012-01-30 |  |  |  |  |  |  |  |  |  |  |  |  |  |  |  |  |  |  |
| 14132909LOE |  | FY09 Proj Admin H-A, All Constrctn (DAQ UPGRADES) | 248d | 2008-10-01 A | 2009-09-30 A | 122132908LOE | 100% |  |  | 100 | 100 | 0 | LEROSE J | 1 | 1 | 07-024 | Z | JOHN L | 09-012 |  |  |  |  |
| 14132910LOE |  | FY10 Proj Admin H-A, All Constrctn (DAQ UPGRADES) | 248d | 2009-10-01 A | 2010-09-30 A | 14132909LOE | 100% |  |  | 100 | 100 | 0 | LEROSE J | 1 | 1 | 07-024 | Z | JOHN L | 09-012 |  |  |  |  |
| 14132911LOE |  | FY11 Proj Admin H-A, All Constrctn (DAQ UPGRADES) | 248d | 2010-10-01 A | 2011-09-30 A | 14132910LOE | 100% |  |  | 100 | 100 | 0 | LEROSE J | 1 | 1 | 07-024 | Z | JOHN L | 09-012 | 1 |  |  |  |
| 14132912LOE |  | FY12 Proj Admin H-A, All Constrctn (DAQ UPGRADES) | 67d | 2011-10-03 A | 2012-01-16 A | 14132911LOE | 100% | 2011-10-03 | 2012-01-13 | 100 | 100 | 0 | LEROSE J | 1 | 1 | 07-024 | E | JOHN L | 09-012 | 31.17408906 | 68.82591093 |  |  |
| 14132018 |  | Proc ADCs, TDCs,¿ (DAQ UPGRADES) | 14d | 2012-01-02 A | 2012-01-23 A | 9-110M FS+60d | 100% | 2012-01-03 | 2012-01-23 |  |  | 0 | LEROSE J | 1 | 1 | 07-024 | Z | JOHN L | 09-012 |  |  | 11-026 |  |
| 14132020 |  | Install Electrnc's (DAQ UPGRADES) | 14d | 2012-01-02 A | 2012-01-23 A | 14132018, 9-120M FS+60d | 100% | 2012-01-03 | 2012-01-23 |  |  | 0 | LEROSE J | 1 | 1 | 07-024 | Z | JOHN L | 09-012 |  |  | 11-026 | Install |
| 14132913LOE |  | FY13 Proj Admin H-A, All Constrctn (DAQ UPGRADES) | 10d | 2012-01-16 A | 2012-01-30 A | 14132912LOE | 100% | 2012-01-17 | 2012-01-30 | 100 | 100 | 0 | LEROSE J | 1 | 1 | 07-024 | E | JOHN L | 09-012 | 0 | 100 |  |  |

| ID | WBS | Activity | Type | Duration | Start | Finish | Predecessors | Complete | Remaining | Planned start | Planned finish | Total float | Free float | Calendar | Resources | Cost | Actual cost | MONTHLY EV COST | RESP - Responsibility | STRT%COMP for CM EVM | FNSH%COMP for CM EVM | Milestone Level | EVMS Reporting Codes | CAM RESPONSIBLE | CR 10-048 | Calculated Remaining Total Cost | PHAS - Project Phase | CR 11-026 | CR 11-038 | CR 11-039 | Remaining Material Cost Based on % Compl | Claimed Material Cost Based on % Complet | Initial Claimed Material Calc | Claimed Material Divider | MARCH!!! | Specification | Installation | OPC Allison | CR 12-053 | ReBaseline Actuals Adjustment | Activities with Steps | BOE NOTES | Original Activity ID Rebaseline | BOE Procurement | BOE Adder | CR 13-015 | Post Rebaseline | Obligated Prior to Rebaseline | Pre Rebaseline Remaining Budget | BOE Labor | BOE Expenses | Previously In Progress |
| --- | --- | --- | --- | --- | --- | --- | --- | --- | --- | --- | --- | --- | --- | --- | --- | --- | --- | --- | --- | --- | --- | --- | --- | --- | --- | --- | --- | --- | --- | --- | --- | --- | --- | --- | --- | --- | --- | --- | --- | --- | --- | --- | --- | --- | --- | --- | --- | --- | --- | --- | --- | --- |
|  | 4 | **1.4.1.4 FAST ELECTRONICS** |  |  |  |  |  |  |  |  |  |  |  |  |  |  |  |  |  |  |  |  |  |  |  |  |  |  |  |  |  |  |  |  |  |  |  |  |  |  |  |  |  |  |  |  |  |  |  |  |  |  |
|  | 5 | **1.4.1.5 BEAMLINE** |  |  | 2011-10-03 | 2013-12-20 |  |  |  |  |  |  |  |  |  |  |  |  |  |  |  |  |  |  |  |  |  |  |  |  |  |  |  |  |  |  |  |  |  |  |  |  |  |  |  |  |  |  |  |  |  |  |
|  | 1 | **1.4.1.5.1 MOLLER POLARIMETER** |  |  | 2011-10-03 | 2013-08-30 |  |  |  |  |  |  |  |  |  |  |  |  |  |  |  |  |  |  |  |  |  |  |  |  |  |  |  |  |  |  |  |  |  |  |  |  |  |  |  |  |  |  |  |  |  |  |
| 14151000M |  | Start Moller polarimeter upgrade (MOL POLAR) | milestone | 0d | 2011-10-03 A | 2011-10-03 A | 9-120M | 100% |  | 2011-11-01 | 2011-11-01 |  |  |  |  |  |  | 0 | LEROSE J | 1 | 1 | 6 | M | JOHN L | 10-048 |  |  |  |  |  |  |  |  |  |  |  |  |  |  |  |  |  |  |  |  |  |  |  |  |  |  |  |
| 14151015 |  | Prepare Quadrupole Manufacturing Drawings Package |  | 54d | 2011-10-03 A | 2011-12-19 A | 9-120M | 100% |  |  |  |  |  |  | MECH DES [120 h] | 5,780.4 | 5,780.4 | 5780.4 | LEROSE J | 1 | 1 |  | H | JOHN L |  | 0 | IN | 11-026 | 11-038 | 11-039 |  |  |  |  |  |  |  |  |  |  |  |  |  |  |  |  |  |  |  |  |  |  |
| 14151020 |  | Quadrupole Procurement prep |  | 98d | 2011-12-19 A | 2012-05-14 A | 14151015 | 100% |  |  |  |  |  |  | MECH ENG [80 h] | 5,609.6 | 5,609.6 | 5609.6 | LEROSE J | 1 | 1 |  | H | JOHN L |  | 0 | IN | 11-026 | 11-038 | 11-039 |  |  |  |  |  |  |  |  |  |  |  |  |  |  |  |  |  |  |  |  |  |  |
| 14151005 |  | Proc Compnts - Stands, Magnetic Shield insert,... (MOL POLAR) |  | 201d | 2012-03-02 A | 2013-02-18 A | 14151000M | 100% |  | 2012-03-02 | 2012-12-14 |  |  |  | PROCUREMENT<$50K 60 | 49,502.95 |  | 49502.95 | LEROSE J | 1 | 1 |  | D | JOHN L | 10-048 | 0 |  |  |  |  | 0 | 49502.95 | 4950295 | 100 | XX |  |  |  |  |  |  |  |  |  |  |  |  |  |  |  |  |  |
| 14151035 |  | Procure/Refurbish Power Supply for Quadrupole |  | 18d | 2012-04-02 A | 2012-04-25 A | 14151020 FS-20d | 100% |  |  |  |  |  |  | PROCUREMENT<$50K 60 | 6,088.21 |  | 6088.21 | LEROSE J | 1 | 1 |  | U | JOHN L |  | 0 | IN | 11-026 | 11-038 | 11-039 | 0 | 6088.21 | 608821 | 100 |  |  |  |  |  |  |  |  |  |  |  |  |  |  |  |  |  |  |
| 14151010 |  | Install Modifications (MOL POLAR) FY12 |  | 145d | 2012-05-21 A | 2013-02-18 A | 14151005 FS-80d, 2-02M, 14151035, 14151030 FS-180d, 3P-01M FS-140d, 14151025 FS-180d | 100% |  | 2012-05-21 | 2012-12-14 |  |  |  | SKLLD TRADE [59.69 h]; ELEC TECH [29.85 h]; SCIENTIST [119.38 h]; COMP SCIENT [29.85 h]; VISTNG USERS [119.38 h]; PLABOR; SUPPLIES & MATERIALS | 20,159.91 | 16,263.79 | 19973.1452 | LEROSE J | 1 | 1 |  | H | JOHN L |  | 0 |  | 11-026 | 11-038 |  |  |  |  |  | XX | 14151010 | Install | OPC A | 12-053 |  |  |  |  |  |  |  |  |  |  |  |  |  |
| 14151010a |  | Install Modifications (MOL POLAR) FY13 |  | 145d | 2012-05-21 A | 2013-02-18 A | 14151010 FS-60d | 100% |  | 2012-05-21 | 2012-12-14 |  |  |  | COMP SCIENT [10.15 h]; SUPPLIES & MATERIALS; VISTNG USERS [40.62 h]; SKLLD TRADE [20.31 h]; SCIENTIST [40.62 h]; PLABOR; ELEC TECH [10.15 h] | 6,901.63 | 5,533.15 | 7011.9309 | LEROSE J | 1 | 1 |  | H | JOHN L |  | 0 | IN | 11-026 | 11-038 |  |  |  |  |  | XX | 14151010 |  |  | 12-053 |  |  |  |  |  |  |  |  |  |  |  |  |  |
| 14151025 |  | Quadrupole Contract Support |  | 78d | 2012-05-28 A | 2012-09-17 A | 14151020 FS-15d | 100% |  | 2012-05-29 | 2012-09-17 |  |  |  | MECH ENG [160 h] | 11,219.2 | 11,219.2 | 11219.2 | LEROSE J | 1 | 1 |  | H | JOHN L |  | 0 | IN | 11-026 | 11-038 | 11-039 |  |  |  |  |  |  |  | OPC A |  |  |  |  |  |  |  |  |  |  |  |  |  |  |
| 14151030 |  | Vend Fab Quadrupole |  | 78d | 2012-05-28 A | 2012-09-17 A | 14151020 FS-20d | 100% |  | 2012-05-29 | 2012-09-17 |  |  |  | PROCUREMENT<$50K 60 | 41,276 |  | 41276 | LEROSE J | 1 | 1 |  | P | JOHN L |  | 0 | IN | 11-026 | 11-038 | 11-039 | 0 | 41276 | 4127600 | 100 |  |  |  | OPC A |  |  |  |  |  |  |  |  |  |  |  |  |  |  |
| 14151040 |  | Re-Baseline Actuals Adjustment |  | 1d | 2013-08-30 A | 2013-08-30 A |  | 100% |  | 2013-09-03 | 2013-09-03 |  |  |  | PROCUREMENT>$50K 69 NO ESCALATION | 76,452.76 |  | 76452.76 |  |  |  |  |  |  |  |  |  |  |  |  | 0 | 76452.76 | 7645276 | 100 |  |  |  |  |  | ADJ |  |  |  |  |  |  |  |  |  |  |  |  |
|  | 2 | **1.4.1.5.2 COMPTON POLARIMETER** |  |  | 2011-10-03 | 2013-12-20 |  |  |  |  |  |  |  |  |  |  |  |  |  |  |  |  |  |  |  |  |  |  |  |  |  |  |  |  |  |  |  |  |  |  |  |  |  |  |  |  |  |  |  |  |  |  |
| 14152000M |  | Start Compton upgrade (COMP POLAR) | milestone | 0d | 2011-10-03 A | 2011-10-03 A | 122152020, 9-120M | 100% |  | 2011-11-01 | 2011-11-01 |  |  |  |  |  |  | 0 | LEROSE J | 1 | 1 | 6 | M | JOHN L | 10-048 |  |  | 11-026 |  |  |  |  |  |  |  |  |  |  |  |  |  |  |  |  |  |  |  |  |  |  |  |  |
| 14152005 |  | Proc Detector componets (COMP POLAR) |  | 36d | 2011-12-01 A | 2012-01-30 A | 14152000M | 100% |  |  |  |  |  |  | PROCUREMENT<$50K 60 | 108,670.15 |  | 108670.15 | LEROSE J | 1 | 1 |  | D | JOHN L | 10-048 | 0 |  | 11-026 |  |  | 0 | 108670.15 | 10867015 | 100 |  |  |  |  |  |  |  |  |  |  |  |  |  |  |  |  |  |  |
| 14152015 |  | Proc motion sys, Stands & Beam Line (COMP POLAR) |  | 264d | 2011-12-01 A | 2013-08-30 A | 14152000M | 100% |  | 2011-12-01 | 2012-12-21 |  |  |  | PROCUREMENT<$50K 60 | 77,150.2 |  | 77150.2 | LEROSE J | 1 | 1 |  | D | JOHN L | 10-048 | 3857.50999999 |  |  |  |  | 0 | 77150.2 | 7715020 | 100 |  |  |  |  |  |  |  |  |  |  |  |  |  |  |  |  |  |  |
| 14152010 |  | Assemble & Test Detector (COMP POLAR) |  | 108d | 2012-01-16 A | 2012-06-19 A | 14152005 | 100% |  | 2012-01-17 | 2012-06-19 |  |  |  | PD UNIV STAFF [80 h]; SCIENTIST [160 h]; PD UNIV STUDNT [200 h]; ELEC TECH [40 h] | 19,692 | 19,692 | 19692 | LEROSE J | 1 | 1 |  | H | JOHN L | 10-048 | 0 |  | 11-026 |  |  |  |  |  |  |  |  |  |  |  |  |  |  |  |  |  |  |  |  |  |  |  |  |
| 14152020 |  | Install & Test (COMP POLAR) FY12 |  | 180d | 2012-06-11 A | 2013-08-30 A | 3P-01M, 2-02M, 14152015 FS-70d, 14152010 FS-20d | 100% |  | 2012-06-11 | 2013-03-04 |  |  |  | MECH TECH [835.69 h]; PD UNIV STUDNT [149.23 h]; SKLLD TRADE [119.38 h]; ELEC TECH [89.54 h]; PD UNIV STAFF [59.69 h]; SCIENTIST [179.08 h] | 63,796.71 | 64,159.28 | 62673.8288 | LEROSE J | 1 | 1 |  | S | JOHN L |  | 52019.277904 |  | 11-026 |  |  |  |  |  |  |  | 14152020 | Install | OPC A | 12-053 |  | ST |  |  |  |  |  |  |  |  |  |  |  |
| 14152025 |  | Install & Test (COMP POLAR) FY13 |  | 180d | 2012-06-11 A | 2013-08-30 A | 14152020 FS-145d | 100% |  | 2012-06-11 | 2013-03-04 |  |  |  | PD UNIV STUDNT [50.77 h]; SCIENTIST [60.92 h]; SKLLD TRADE [40.62 h]; ELEC TECH [30.46 h]; PD UNIV STAFF [20.31 h]; MECH TECH [284.31 h] | 21,704.19 | 21,827.81 | 22002.9901 | LEROSE J | 1 | 1 |  | S | JOHN L |  | 18262.481783 | IN | 11-026 |  |  |  |  |  |  |  | 14152020 |  |  | 12-053 |  | ST |  |  |  |  |  |  |  |  |  |  |  |
| 14152030 |  | Re-Baseline Actuals Adjustment |  | 1d | 2013-08-30 A | 2013-08-30 A |  | 100% |  | 2013-09-03 | 2013-09-03 |  |  |  | PROCUREMENT>$50K 69 NO ESCALATION | 15,961.76 |  | 15961.76 |  |  |  |  |  |  |  |  |  |  |  |  | 0 | 15961.76 | 1596176 | 100 |  |  |  |  |  | ADJ |  |  |  |  |  |  |  |  |  |  |  |  |
| 24152015 |  | Proc motion sys, Stands & Beam Line (COMP POLAR) Re-Baseline Obligation Split |  | 20d | 2013-09-03 A | 2013-12-20 | 9-130M FS+228d |  | 34d | 2013-10-01 | 2013-10-28 | 45d | 6d | 8/5 M-F w/JLAB Holidays ReBaseline | PROCUREMENT<$50K 60 | 12 |  | 0 | LEROSE J | 1 | 1 |  | S | JOHN L | 10-048 |  |  |  |  |  | 12 | 0 | 0 | 100 |  |  |  |  |  |  | ST | This is essentially done | 24152015 | OB | NO | 13-015 | PR | OB |  |  |  |  |
| 24152020 |  | Proc motion sys, Stands & Beam Line (COMP POLAR) |  | 20d | 2013-10-01 A | 2013-12-20 | 9-130M FS+228d |  | 34d | 2013-11-01 | 2013-12-02 | 45d | 6d | 8/5 M-F w/JLAB Holidays ReBaseline | PROCUREMENT<$50K 60 | 3,845.51 |  | 0 | LEROSE J | 1 | 1 |  | S | JOHN L | 10-048 |  |  |  |  |  | 3845.51 | 0 | 0 | 100 |  |  |  |  |  |  | ST | This is essentially done | 24152015 | OB | NO | 13-015 | PR | OB-2 |  |  |  |  |
| 24152025 |  | Install & Test (COMP POLAR) |  | 20d | 2013-10-01 A | 2013-12-20 | 24152015 FS-40d, 24152020 FS-40d |  | 34d | 2013-11-01 | 2013-12-02 | 39d | 0d | 8/5 M-F w/JLAB Holidays ReBaseline | MECH TECH [80 h]; MECH DES [40 h] | 5,837.6 | 2,355.52 | 0 | LEROSE J | 1 | 1 |  | S | JOHN L |  |  | IN | 11-026 |  |  |  |  |  |  |  |  |  |  | 12-053 |  | ST | work in progress | 24152025 |  | NO | 13-015 | PR |  | 82136.51 | PE | PE | Review |

Notes:
- 14152020: Steps: dissassembly completed (done); magnets and table repositioned (done); beamline and detectors installed (done); magnet power restored and checked (done); completed (lasers ready etc.) (done)
- 14152025: Steps: dissassembly completed (done); magnets and table repositioned (done); beamline and detectors installed (done); magnet power restored and checked (done); completed (lasers ready etc.) (done)
- 24152015: Steps: Proc motion sys, Stands & Beam Line (COMP POLAR) Re-Baseline Obligation Split
- 24152020: Steps: Proc motion sys, Stands & Beam Line (COMP POLAR)
- 24152025: Steps: Install & Test (COMP POLAR)

| ID | WBS | Activity | Type | Duration | Start | Finish | Predecessors | Complete | Planned start | Planned finish | Calendar | Resources | Cost | Actual cost | Calculated Remaining Total Cost | MONTHLY EV COST | RESP - Responsibility | STRT%COMP for CM EVM | FNSH%COMP for CM EVM | CR 08-010 | EVMS Reporting Codes | CAM RESPONSIBLE | CR 09-003 | CR 09-012 | CR 10-030 | CR 10-048 | CR 11-026 | OPC Allison | Milestone Level | CR 08-052 | MARCH!!! | Installation | Claimed Material Divider | ReBaseline Actuals Adjustment | BOE NOTES | Original Activity ID Rebaseline | PHAS - Project Phase | BOE Adder | CR 13-015 | Post Rebaseline | LOE Divider | LOE Multiplier | CR 07-024 | CR 08-058 | Remaining Material Cost Based on % Compl | Claimed Material Cost Based on % Complet | Initial Claimed Material Calc | Advance Purchase Plan > 500K | CR 08-016 | 12 GEV MAJOR PROCUREMENT CATAGORY | CR 09-049 | CR 11-035 | CR 12-024 | CR 08-039 | CR 10-044 | 12 GeV 4th level Critical Path | Activities with Steps | CR 11-023 | Schedule Contingency | CR 11-001 | LOE % Pre Calc | LOE % | CR 12-001 | CR 12-053 | PRIOR MONTH EV COST | CR 12-055 | CR 13-002 | BOE Procurement | Obligated Prior to Rebaseline | CR 13-016 |
| --- | --- | --- | --- | --- | --- | --- | --- | --- | --- | --- | --- | --- | --- | --- | --- | --- | --- | --- | --- | --- | --- | --- | --- | --- | --- | --- | --- | --- | --- | --- | --- | --- | --- | --- | --- | --- | --- | --- | --- | --- | --- | --- | --- | --- | --- | --- | --- | --- | --- | --- | --- | --- | --- | --- | --- | --- | --- | --- | --- | --- | --- | --- | --- | --- | --- | --- | --- | --- | --- | --- |
|  | 3 | **1.4.1.5.3 MAPPING-ARC ENERGY MEASUREMENT** |  |  | 2013-03-01 | 2013-10-14 |  |  |  |  |  |  |  |  |  |  |  |  |  |  |  |  |  |  |  |  |  |  |  |  |  |  |  |  |  |  |  |  |  |  |  |  |  |  |  |  |  |  |  |  |  |  |  |  |  |  |  |  |  |  |  |  |  |  |  |  |  |  |  |  |
| 14153010 |  | Calibrate and Install H-A Line Magnets |  | 77d | 2013-03-01 A | 2013-05-13 A | 2-02M FS+60d, 14153000M | 100% | 2013-04-01 | 2013-07-18 |  | TRAVEL; SCIENTIST [480 h]; PD UNIV STUDNT [600 h]; MECH TECH [608 h]; ELEC TECH [88 h]; SUPPLIES & MATERIALS; VISTNG USERS [480 h] | 90,982.04 | 83,045.2 | 0 | 88413 | LEROSE J | 1 | 1 | 08-010 | D | JOHN L | 09-003 | 09-012 | 10-030 | 10-048 | 11-026 | OPC A |  |  |  |  |  |  |  |  |  |  |  |  |  |  |  |  |  |  |  |  |  |  |  |  |  |  |  |  |  |  |  |  |  |  |  |  |  |  |  |  |  |  |
| 14153000M |  | Start Calibration | milestone | 0d | 2013-05-03 A | 2013-05-03 A | 9-130M FS+25d, 2-02M FS+80d, 122153010, 9-110M | 100% | 2013-06-03 | 2013-06-03 |  |  |  |  |  | 0 | LEROSE J | 1 | 1 |  | M | JOHN L |  |  |  | 10-048 | 11-026 |  | 6 | 08-052 | XX |  |  |  |  |  |  |  |  |  |  |  |  |  |  |  |  |  |  |  |  |  |  |  |  |  |  |  |  |  |  |  |  |  |  |  |  |  |  |  |
| 14153020 |  | Install Mapper & Rebuilt 9th Dipole in Shed (MAPPER) |  | 1d | 2013-08-30 A | 2013-08-30 A | 14153010 | 100% | 2013-09-03 | 2013-09-03 |  |  |  |  |  | 0 | LEROSE J | 1 | 1 | 08-010 | Z | JOHN L | 09-003 | 09-012 | 10-030 | 10-048 | 11-026 | OPC A |  |  |  | Install |  |  |  |  |  |  |  |  |  |  |  |  |  |  |  |  |  |  |  |  |  |  |  |  |  |  |  |  |  |  |  |  |  |  |  |  |  |  |
| 14153025 |  | Re-Baseline Actuals Adjustment |  | 1d | 2013-08-30 A | 2013-08-30 A |  | 100% | 2013-09-03 | 2013-09-03 |  | PROCUREMENT>$50K 69 NO ESCALATION | -27,482.98 |  |  |  |  |  |  |  |  |  |  |  |  |  |  |  |  |  |  |  | 100 | ADJ |  |  |  |  |  |  |  |  |  |  |  |  |  |  |  |  |  |  |  |  |  |  |  |  |  |  |  |  |  |  |  |  |  |  |  |  |
| 24153020 |  | Install Rebuilt 9th Dipole in Shed (MAPPER) |  | 1d | 2013-10-01 A | 2013-10-14 A | 9-130M FS+228d | 100% | 2013-11-01 | 2013-11-01 | 8/5 M-F w/JLAB Holidays ReBaseline |  |  |  |  | 0 | LEROSE J | 1 | 1 | 08-010 | Z | JOHN L |  | 09-012 | 10-030 | 10-048 | 11-026 |  |  |  |  |  |  |  | This is never going to happen (HELLO!) | 24153020 | IN | NO | 13-015 | PR |  |  |  |  |  |  |  |  |  |  |  |  |  |  |  |  |  |  |  |  |  |  |  |  |  |  |  |  |  |  |
|  | 6 | **1.4.1.6 INFRASTRUCTURE** |  |  |  |  |  |  |  |  |  |  |  |  |  |  |  |  |  |  |  |  |  |  |  |  |  |  |  |  |  |  |  |  |  |  |  |  |  |  |  |  |  |  |  |  |  |  |  |  |  |  |  |  |  |  |  |  |  |  |  |  |  |  |  |  |  |  |  |  |
|  | 1 | **1.4.1.6.1 ENGINEERING & DESIGN** |  |  |  |  |  |  |  |  |  |  |  |  |  |  |  |  |  |  |  |  |  |  |  |  |  |  |  |  |  |  |  |  |  |  |  |  |  |  |  |  |  |  |  |  |  |  |  |  |  |  |  |  |  |  |  |  |  |  |  |  |  |  |  |  |  |  |  |  |
|  | 2 | **1.4.1.6.2 CABLING** |  |  |  |  |  |  |  |  |  |  |  |  |  |  |  |  |  |  |  |  |  |  |  |  |  |  |  |  |  |  |  |  |  |  |  |  |  |  |  |  |  |  |  |  |  |  |  |  |  |  |  |  |  |  |  |  |  |  |  |  |  |  |  |  |  |  |  |  |
|  | 3 | **1.4.1.6.3 INSTALLATION** |  |  |  |  |  |  |  |  |  |  |  |  |  |  |  |  |  |  |  |  |  |  |  |  |  |  |  |  |  |  |  |  |  |  |  |  |  |  |  |  |  |  |  |  |  |  |  |  |  |  |  |  |  |  |  |  |  |  |  |  |  |  |  |  |  |  |  |  |
|  | 2 | **1.4.2 CONSTRUCTION HALL B** |  |  | 2009-01-02 | 2016-05-12 |  |  |  |  |  |  |  |  |  |  |  |  |  |  |  |  |  |  |  |  |  |  |  |  |  |  |  |  |  |  |  |  |  |  |  |  |  |  |  |  |  |  |  |  |  |  |  |  |  |  |  |  |  |  |  |  |  |  |  |  |  |  |  |  |
|  | 1 | **1.4.2.1 MAGNET** |  |  | 2009-01-02 | 2013-09-16 |  |  |  |  |  |  |  |  |  |  |  |  |  |  |  |  |  |  |  |  |  |  |  |  |  |  |  |  |  |  |  |  |  |  |  |  |  |  |  |  |  |  |  |  |  |  |  |  |  |  |  |  |  |  |  |  |  |  |  |  |  |  |  |  |
|  | 1 | **1.4.2.1.1 TOROIDAL MAGNET** |  |  | 2009-01-02 | 2013-09-16 |  |  |  |  |  |  |  |  |  |  |  |  |  |  |  |  |  |  |  |  |  |  |  |  |  |  |  |  |  |  |  |  |  |  |  |  |  |  |  |  |  |  |  |  |  |  |  |  |  |  |  |  |  |  |  |  |  |  |  |  |  |  |  |  |
| 14211009E |  | Torus FY09 Travel |  | 189d | 2009-01-02 A | 2009-09-30 A | 14211009EX | 100% |  |  |  | TRAVEL | 6,086.21 |  | 0 | 6086.208114 | ELOUADRHIRI L | 1 | 1 |  | E | LATIFA E |  |  |  |  |  |  |  |  |  |  |  |  |  |  |  |  |  |  | 100 | 100 | 07-024 | 08-058 |  |  |  |  |  |  |  |  |  |  |  |  |  |  |  |  |  |  |  |  |  |  |  |  |  |  |
| 14211030 |  | Vend Fab Torus - Completion of System Requirements Review (SRR) (1) |  | 19d | 2009-09-04 A | 2009-10-01 A | 9-090M FS+230d | 100% |  |  |  | PROCUREMENT<$50K 60 NO ESCALATION; PROCUREMENT>$50K 69 NO ESCALATION | 112,000 |  | 0 | 112000 | ELOUADRHIRI L | 1 | 1 |  | P | LATIFA E |  | 09-012 |  |  | 11-026 |  |  |  |  |  | 100 |  |  |  |  |  |  |  |  |  |  |  | 0 | 112000 | 11200000 | APP | 08-016 | 4211 | 09-049 | 11 -035 | 12-024F |  |  |  |  |  |  |  |  |  |  |  |  |  |  |  |  |  |
| 14211035 |  | Vend Fab Torus - Completion of Preliminary Design Review (2) |  | 65d | 2009-09-04 A | 2009-12-08 A | 14211030 FS-40d | 100% |  |  |  | PROCUREMENT>$50K 69 NO ESCALATION | 274,000 |  | 0 | 274000 | ELOUADRHIRI L | 1 | 1 |  | P | LATIFA E |  | 09-012 |  |  | 11-026 |  |  |  |  |  | 100 |  |  |  |  |  |  |  |  |  |  |  | 0 | 274000 | 27400000 | APP | 08-016 | 4211 | 09-049 | 11 -035 | 12-024F | 08-039 |  |  |  |  |  |  |  |  |  |  |  |  |  |  |  |  |
| 14211040 |  | Vend Fab Torus - Superconductor Production |  | 116d | 2009-09-04 A | 2010-03-01 A | 14211035 FS-76d | 100% |  |  |  | PROCUREMENT>$50K 69 NO ESCALATION | 262,000 |  | 0 | 262000 | ELOUADRHIRI L | 1 | 1 |  | P | LATIFA E |  | 09-012 |  |  | 11-026 |  |  |  |  |  | 100 |  |  |  |  |  |  |  |  |  |  |  | 0 | 262000 | 26200000 | APP | 08-016 | 4211 | 09-049 | 11 -035 | 12-024F |  | 10-044 |  |  |  |  |  |  |  |  |  |  |  |  |  |  |  |
| 14211045 |  | Vend Fab Torus - Completion of Preliminary Design Review and Manufacturing Readiness Review |  | 116d | 2009-09-04 A | 2010-03-01 A | 14211040 FS-96d, 14211040B FS-288d, 14211040A FS-116d | 100% |  |  |  | PROCUREMENT>$50K 69 NO ESCALATION | 324,000 |  | 0 | 324000 | ELOUADRHIRI L | 1 | 1 |  | P | LATIFA E |  | 09-012 |  |  | 11-026 |  |  |  |  |  | 100 |  |  |  | IN |  |  |  |  |  |  |  | 0 | 324000 | 32400000 | APP | 08-016 | 4211 | 09-049 | 11 -035 | 12-024F |  | 10-044 |  |  |  |  |  |  |  |  |  |  |  |  |  |  |  |
| 14211004 |  | Torus Vend Comp Dsgn & Fab FY09 Original Labor Initial |  | 265d | 2009-10-01 A | 2010-10-25 A | 14211002X FS-170d, 14211000MX | 100% |  |  |  | ELEC TECH [54.53 h]; OFFICE [54.5 h]; MECH ENG [245.39 h]; MECH DES [163.59 h]; SCIENTIST [190.86 h]; MECH TECH [545.31 h]; ELEC ENG [136.33 h]; ELEC DES [190.86 h] | 80,952.53 | 80,952.53 | 0 | 78291.1734 | ELOUADRHIRI L | 1 | 1 |  | S | LATIFA E |  | 09-012 |  |  | 11-026 |  |  |  |  |  |  |  |  |  |  |  |  |  |  |  |  |  |  |  |  | APP | 08-016 | 4211 | 09-049 | 11 -035 |  |  |  | 4 | ST |  |  |  |  |  |  |  |  |  |  |  |  |  |
| 14211004A |  | Torus Vend Comp Dsgn & Fab FY09 Original Labor Final |  | 265d | 2009-10-01 A | 2010-10-25 A | 14211004 FS-500d, 9-090M FS+227d | 100% |  |  |  | ELEC DES [24 h]; ELEC ENG [17.14 h]; ELEC TECH [6.86 h]; MECH DES [20.57 h]; MECH ENG [30.86 h]; MECH TECH [68.57 h]; SCIENTIST [24 h]; OFFICE [6.86 h] | 10,179.74 | 10,179.74 | 0 | 9845.0731 | ELOUADRHIRI L | 1 | 1 |  | S | LATIFA E |  |  |  |  | 11-026 |  |  |  |  |  |  |  |  |  |  |  |  |  |  |  |  |  |  |  |  | APP |  | 4211 | 09-049 | 11 -035 |  |  |  | 4 | ST |  |  |  |  |  |  |  |  |  |  |  |  |  |
| 14211004B |  | Torus Vend Comp Dsgn & Fab FY10 Original Labor |  | 265d | 2009-10-01 A | 2010-10-25 A | 9-100M | 100% |  |  |  | SCIENTIST [65.14 h]; OFFICE [18.61 h]; MECH TECH [186.12 h]; MECH ENG [83.75 h]; MECH DES [55.84 h]; ELEC TECH [18.61 h]; ELEC ENG [46.53 h]; ELEC DES [65.14 h] | 27,629.71 | 27,629.71 | 0 | 27573.3246 | ELOUADRHIRI L | 1 | 1 |  | S | LATIFA E |  |  |  |  | 11-026 |  |  |  |  |  |  |  |  |  |  |  |  |  |  |  |  |  |  |  |  | APP |  | 4211 | 09-049 | 11 -035 |  |  |  | 4 | ST |  |  |  |  |  |  |  |  |  |  |  |  |  |
| 14211010E |  | Torus FY10 Travel |  | 248d | 2009-10-01 A | 2010-09-30 A | 14211009E | 100% |  |  |  | TRAVEL | 8,240.89 |  | 0 | 8240.887547 | ELOUADRHIRI L | 1 | 1 |  | E | LATIFA E |  |  |  |  |  |  |  |  |  |  |  |  |  |  |  |  |  |  | 100 | 100 | 07-024 |  |  |  |  |  |  |  |  |  |  |  |  |  |  |  |  |  |  |  |  |  |  |  |  |  |  |  |
| 14211040C |  | Vend Fab Torus -Solder Stabilizer Production |  | 556d | 2009-11-02 A | 2012-02-06 A | 14211040B FS-247d | 100% |  |  |  | PROCUREMENT>$50K 69 NO ESCALATION | 70,000 |  | 0 | 70000 | ELOUADRHIRI L | 1 | 1 |  | S | LATIFA E |  |  |  |  | 11-026 |  |  |  |  |  | 100 |  |  |  |  |  |  |  |  |  |  |  | 0 | 70000 | 7000000 | APP |  | 4211 |  | 11 -035 | 12-024F |  | 10-044 |  | ST | 11-023 |  |  |  |  |  |  |  |  |  |  |  |  |
| 14211050Ab |  | Vend Fab Torus - Stability Model Coil test (5b) |  | 556d | 2009-11-02 A | 2012-02-06 A | 14211050A FS-346d | 100% |  |  |  | PROCUREMENT>$50K 69 NO ESCALATION | 55,409 |  | 0 | 55409 | ELOUADRHIRI L | 1 | 1 |  | P | LATIFA E |  |  |  |  | 11-026 |  |  |  |  |  | 100 |  |  |  | IN |  |  |  |  |  |  |  | 0 | 55409 | 5540900 | APP |  | 4211 |  | 11 -035 | 12-024F |  | 10-044 |  |  | 11-023 | SC |  |  |  |  |  |  |  |  |  |  |  |
| 14211050Ac |  | Vend Fab Torus - UG&GUG Duties (17P1) |  | 347d | 2009-11-02 A | 2011-04-01 A | 14211050Ab FS-390d | 100% |  |  |  | PROCUREMENT>$50K 69 NO ESCALATION | 101,459 |  | 0 | 101459 | ELOUADRHIRI L | 1 | 1 |  | P | LATIFA E |  |  |  |  | 11-026 |  |  |  |  |  | 100 |  |  |  | IN |  |  |  |  |  |  |  | 0 | 101459 | 10145900 | APP |  | 4211 |  | 11 -035 | 12-024F |  | 10-044 |  |  | 11-023 | SC |  |  |  |  |  |  |  |  |  |  |  |
| 14211050Ad |  | Vend Fab Torus - Coil Case Plates-Mill run Phase 2 Funding (17P2) |  | 347d | 2009-11-02 A | 2011-04-01 A | 14211050Ac FS-323d | 100% |  |  |  | PROCUREMENT>$50K 69 NO ESCALATION | 41,532 |  | 0 | 41532 | ELOUADRHIRI L | 1 | 1 |  | P | LATIFA E |  |  |  |  | 11-026 |  |  |  |  |  | 100 |  |  |  | IN |  |  |  |  |  |  |  | 0 | 41532 | 4153200 | APP |  | 4211 |  | 11 -035 | 12-024F |  | 10-044 |  |  | 11-023 | SC |  |  |  |  |  |  |  |  |  |  |  |
| 14211050 |  | Vend Fab Torus -Design and Construction of Prototype Coil (Full Size) (5a) |  | 449d | 2009-12-01 A | 2011-09-22 A | 14211045A FS-76d, 14211045 FS-75d, 14211045D FS-340d | 100% |  |  |  | PROCUREMENT<$50K 60 NO ESCALATION; PROCUREMENT>$50K 69 NO ESCALATION | 203,000 |  | 0 | 203000 | ELOUADRHIRI L | 1 | 1 |  | S | LATIFA E |  |  |  |  | 11-026 |  |  |  |  |  | 100 |  |  |  | IN |  |  |  |  |  |  |  | 0 | 203000 | 20300000 | APP |  | 4211 | 09-049 | 11 -035 | 12-024F |  | 10-044 |  | ST |  | SC |  |  |  |  |  |  |  |  |  |  |  |
| 14211055 |  | Vend Fab Torus -Complete and Warm Test Coil #1 (6) |  | 537d | 2009-12-01 A | 2012-02-06 A | 14211050 FS-220d, 14211050A FS-346d | 100% |  |  |  | PROCUREMENT>$50K 69 NO ESCALATION | 282,600 |  | 0 | 282600 | ELOUADRHIRI L | 1 | 1 |  | P | LATIFA E |  |  |  |  | 11-026 |  |  |  |  |  | 100 |  |  |  | IN |  |  |  |  |  |  |  | 0 | 282600 | 28260000 | APP |  | 4211 | 09-049 | 11 -035 | 12-024F |  | 10-044 |  | NB | 11-023 | SC |  |  |  |  |  |  |  |  |  |  |  |
| 14211060 |  | Vend Fab Torus -Complete and Warm Test Coil #2 (7) |  | 537d | 2009-12-01 A | 2012-02-06 A | 14211055 FS-495d | 100% |  |  |  | PROCUREMENT>$50K 69 NO ESCALATION | 235,000 |  | 0 | 235000 | ELOUADRHIRI L | 1 | 1 |  | P | LATIFA E |  |  |  |  | 11-026 |  |  |  |  |  | 100 |  |  |  | IN |  |  |  |  |  |  |  | 0 | 235000 | 23500000 | APP |  | 4211 | 09-049 | 11 -035 | 12-024F |  | 10-044 |  | NB | 11-023 | SC |  |  |  |  |  |  |  |  |  |  |  |
| 14211010 |  | Torus Vend Coil Winding Original Labor FY10 |  | 245.15d | 2010-01-04 A | 2010-12-29 A | 14211004B FS-200d, 9-100M FS+60d, 14211004 FS-200d | 100% |  |  |  | SCIENTIST [184.16 h]; ELEC DES [214.86 h]; ELEC ENG [153.47 h]; ELEC TECH [61.39 h]; MECH DES [184.16 h]; MECH ENG [276.24 h]; MECH TECH [767.35 h] | 94,354.54 | 94,354.54 | 0 | 93670.6718 | ELOUADRHIRI L | 1 | 1 |  | E | LATIFA E |  |  |  |  | 11-026 |  |  |  |  |  |  |  |  |  |  |  |  |  | 100 | 100 |  |  |  |  |  | APP |  | 4211 | 09-049 | 11 -035 |  |  |  | 4 |  |  |  | 11-001 |  |  |  |  |  |  |  |  |  |  |
| 14211010a |  | Torus Vend Coil Winding Original Labor FY11 |  | 245.33d | 2010-01-04 A | 2010-12-29 A | 9-100M FS+60d, 14211004B FS-200d, 14211004 FS-200d | 100% |  |  |  | SCIENTIST [55.84 h]; ELEC DES [65.14 h]; ELEC ENG [46.53 h]; ELEC TECH [18.61 h]; MECH DES [55.84 h]; MECH ENG [83.76 h]; MECH TECH [232.65 h] | 28,608.37 | 28,608.37 | 0 | 29305.744 | ELOUADRHIRI L | 1 | 1 |  | E | LATIFA E |  |  |  |  | 11-026 |  |  |  |  |  |  |  |  |  |  |  |  |  | 100 | 100 |  |  |  |  |  | APP |  | 4211 | 09-049 | 11 -035 |  |  |  | 4 |  |  |  | 11-001 |  |  |  |  |  |  |  |  |  |  |
| 14211015 |  | Torus Vend Compnts Fab Original Labor FY10 |  | 246d | 2010-01-04 A | 2010-12-29 A | 14211004B FS-200d, 14211004 FS-200d, 9-100M FS+60d | 100% |  |  |  | MECH DES [122.78 h]; MECH ENG [214.86 h]; MECH TECH [306.94 h]; SCIENTIST [92.08 h]; SKLLD TRADE [36.83 h]; ELEC DES [61.39 h]; ELEC ENG [61.39 h]; ELEC TECH [46.04 h] | 49,026.26 | 49,026.26 | 0 | 48666.8121 | ELOUADRHIRI L | 1 | 1 |  | E | LATIFA E |  |  |  |  | 11-026 |  |  |  |  |  |  |  |  |  |  |  |  |  | 100 | 100 |  |  |  |  |  | APP |  | 4211 | 09-049 | 11 -035 |  |  |  | 4 |  |  |  | 11-001 |  |  |  |  |  |  |  |  |  |  |
| 14211015a |  | Torus Vend Compnts Fab Original Labor FY11 |  | 246d | 2010-01-04 A | 2010-12-29 A | 14211004B FS-200d, 9-100M FS+60d, 14211004 FS-200d | 100% |  |  |  | ELEC TECH [13.96 h]; MECH DES [37.22 h]; MECH ENG [65.14 h]; SCIENTIST [27.92 h]; SKLLD TRADE [11.17 h]; ELEC DES [18.61 h]; ELEC ENG [18.61 h]; MECH TECH [93.06 h] | 14,863.72 | 14,863.72 | 0 | 15225.0643 | ELOUADRHIRI L | 1 | 1 |  | E | LATIFA E |  |  |  |  | 11-026 |  |  |  |  |  |  |  |  |  |  |  |  |  | 100 | 100 |  |  |  |  |  | APP |  | 4211 | 09-049 | 11 -035 |  |  |  | 4 |  |  |  | 11-001 |  |  |  |  |  |  |  |  |  |  |
| 14211040A |  | Vend Fab Torus - Superconductor Production Reverse Entry per CR10-044 |  | 1d | 2010-03-01 A | 2010-03-01 A | 9-100M FS+97d | 100% |  |  |  | PROCUREMENT>$50K 69 NO ESCALATION | -262,000 |  |  |  | ELOUADRHIRI L | 1 | 1 |  | P | LATIFA E |  |  |  |  | 11-026 |  |  |  |  |  | 100 |  |  |  |  |  |  |  |  |  |  |  |  |  |  | APP |  | 4211 |  | 11 -035 | 12-024F |  | 10-044 |  |  |  |  |  |  |  |  |  |  |  |  |  |  |  |
| 14211040B |  | Vend Fab Torus - Superconductor Production Revised Delivery per CR10-044 (3a, 3b, 3c) |  | 308d | 2010-03-01 A | 2011-05-23 A | 9-100M FS+97d | 100% |  |  |  | PROCUREMENT>$50K 69 NO ESCALATION | 262,000 |  | 0 | 262000 | ELOUADRHIRI L | 1 | 1 |  | S | LATIFA E |  |  |  |  | 11-026 |  |  |  |  |  | 100 |  |  |  |  |  |  |  |  |  |  |  | 0 | 262000 | 26200000 | APP |  | 4211 |  | 11 -035 | 12-024F |  | 10-044 |  | ST |  |  |  |  |  |  |  |  |  |  |  |  |  |
| 14211045A |  | Vend Fab Torus - Completion of Preliminary Design Review and Manufacturing Readiness Review Reverse Entry per CR10-044 |  | 1d | 2010-03-01 A | 2010-03-01 A | 9-100M FS+97d | 100% |  |  |  | PROCUREMENT>$50K 69 NO ESCALATION | -324,000 |  |  |  | ELOUADRHIRI L | 1 | 1 |  | P | LATIFA E |  |  |  |  | 11-026 |  |  |  |  |  | 100 |  |  |  | IN |  |  |  |  |  |  |  |  |  |  | APP |  | 4211 |  | 11 -035 | 12-024F |  | 10-044 |  |  |  |  |  |  |  |  |  |  |  |  |  |  |  |
| 14211045B |  | Vend Fab Torus - Completion of IDR Revised Delivery per CR10-044 (4A) |  | 107d | 2010-03-01 A | 2010-07-29 A | 9-100M FS+97d | 100% |  |  |  | PROCUREMENT>$50K 69 NO ESCALATION | 108,000 |  | 0 | 108000 | ELOUADRHIRI L | 1 | 1 |  | P | LATIFA E |  |  |  |  | 11-026 |  |  |  |  |  | 100 |  |  |  | IN |  |  |  |  |  |  |  | 0 | 108000 | 10800000 | APP |  | 4211 |  | 11 -035 | 12-024F |  | 10-044 |  |  |  | SC |  |  |  |  |  |  |  |  |  |  |  |
| 14211045C |  | Vend Fab Torus - Completion of FDR Revised Delivery per CR10-044 (4B) |  | 204d | 2010-03-01 A | 2010-12-16 A | 14211045B FS-172d, 9-100M FS+97d | 100% |  |  |  | PROCUREMENT>$50K 69 NO ESCALATION | 108,000 |  | 0 | 108000 | ELOUADRHIRI L | 1 | 1 |  | S | LATIFA E |  |  |  |  | 11-026 |  |  |  |  |  | 100 |  |  |  | IN |  |  |  |  |  |  |  | 0 | 108000 | 10800000 | APP |  | 4211 |  | 11 -035 | 12-024F |  | 10-044 |  | ST |  | SC |  |  |  |  |  |  |  |  |  |  |  |
| 14211045D |  | Vend Fab Torus - Completion Manufacturing Readiness ReviewRevised Delivery per CR10-044 (4C1, 4C2) |  | 481d | 2010-03-01 A | 2012-02-06 A | 14211045C FS-229d, 9-100M FS+97d | 100% |  |  |  | PROCUREMENT>$50K 69 NO ESCALATION | 108,000 |  | 0 | 108000 | ELOUADRHIRI L | 1 | 1 |  | S | LATIFA E |  |  |  |  | 11-026 |  |  |  |  |  | 100 |  |  |  | IN |  |  |  |  |  |  |  | 0 | 108000 | 10800000 | APP |  | 4211 |  | 11 -035 | 12-024F |  | 10-044 |  | ST |  | SC |  |  |  |  |  |  |  |  |  |  |  |
| 14211050A |  | Vend Fab Torus - Testing of Prototype Coil (Full Size) (5c,5d) |  | 481d | 2010-03-01 A | 2012-02-06 A | 14211045A FS-76d, 14211045D FS-340d, 14211045 FS-75d | 100% |  |  |  | PROCUREMENT>$50K 69 NO ESCALATION | 203,000 |  | 0 | 203000 | ELOUADRHIRI L | 1 | 1 |  | S | LATIFA E |  |  |  |  | 11-026 |  |  |  |  |  | 100 |  |  |  | IN |  |  |  |  |  |  |  | 0 | 203000 | 20300000 | APP |  | 4211 |  | 11 -035 | 12-024F |  | 10-044 |  | ST |  | SC |  |  |  |  |  |  |  |  |  |  |  |
| 14211011E |  | Torus FY11 Travel |  | 248d | 2010-10-01 A | 2011-09-30 A | 14211010E | 100% |  |  |  | TRAVEL | 8,503.77 |  | 0 | 8503.77 | ELOUADRHIRI L | 1 | 1 |  | E | LATIFA E |  |  |  |  |  |  |  |  |  |  |  |  |  |  |  |  |  |  | 100 | 100 | 07-024 |  |  |  |  |  |  |  |  |  |  |  |  |  |  |  |  |  | 8.46774193 | 91.53225806 |  |  |  |  |  |  |  |  |
| 14211050AdA |  | Vend Fab Torus - Coil Case Plates-Mill run Phase 3 Funding (17P2) |  | 100d | 2010-11-01 A | 2011-04-01 A | 14211050Ad FS-99d | 100% |  |  |  | PROCUREMENT>$50K 69 NO ESCALATION | 22,799 |  | 0 | 22799 | ELOUADRHIRI L | 1 | 1 |  | P | LATIFA E |  |  |  |  | 11-026 |  |  |  |  |  | 100 |  |  |  | IN |  |  |  |  |  |  |  | 0 | 22799 | 2279900 | APP |  | 4211 |  | 11 -035 | 12-024F |  | 10-044 |  |  | 11-023 | SC |  |  |  |  |  |  |  |  |  |  |  |
| 14211051 |  | Vend Fab Torus - Coil Case Plates-CNC machining (17P3) |  | 309d | 2010-11-01 A | 2012-02-06 A | 14211050AdA FS-99d | 100% |  |  |  | PROCUREMENT>$50K 69 NO ESCALATION | 56,225 |  | 0 | 56225 | ELOUADRHIRI L | 1 | 1 |  | P | LATIFA E |  |  |  |  | 11-026 |  |  |  |  |  | 100 |  |  |  | IN |  |  |  |  |  |  |  | 0 | 56225 | 5622500 | APP |  | 4211 |  | 11 -035 | 12-024F |  | 10-044 |  |  | 11-023 | SC |  |  |  |  |  |  |  |  |  |  |  |
| 14211051a |  | Vend Fab Torus - He tracing Tube - OFHC (17P4) |  | 100d | 2010-11-01 A | 2011-04-01 A | 14211051 FS-206d | 100% |  |  |  | PROCUREMENT>$50K 69 NO ESCALATION | 16,291 |  | 0 | 16291 | ELOUADRHIRI L | 1 | 1 |  | P | LATIFA E |  |  |  |  | 11-026 |  |  |  |  |  | 100 |  |  |  | IN |  |  |  |  |  |  |  | 0 | 16291 | 1629100 | APP |  | 4211 |  | 11 -035 | 12-024F |  | 10-044 |  |  | 11-023 | SC |  |  |  |  |  |  |  |  |  |  |  |
| 14211051b |  | Vend Fab Torus - Torus Vac Vessel Plate-Mill run (17P5) |  | 100d | 2010-11-01 A | 2011-04-01 A | 14211051a FS-206d | 100% |  |  |  | PROCUREMENT>$50K 69 NO ESCALATION | 125,000 |  | 0 | 125000 | ELOUADRHIRI L | 1 | 1 |  | P | LATIFA E |  |  |  |  | 11-026 |  |  |  |  |  | 100 |  |  |  | IN |  |  |  |  |  |  |  | 0 | 125000 | 12500000 | APP |  | 4211 |  | 11 -035 | 12-024F |  | 10-044 |  |  | 11-023 | SC |  |  |  |  |  |  |  |  |  |  |  |
| 14211051c |  | Vend Fab Torus - Nitrogen tracing tube (17P6) |  | 218d | 2010-11-01 A | 2011-09-19 A | 14211051b FS-206d | 100% |  |  |  | PROCUREMENT>$50K 69 NO ESCALATION | 7,425 |  | 0 | 7425 | ELOUADRHIRI L | 1 | 1 |  | P | LATIFA E |  |  |  |  | 11-026 |  |  |  |  |  | 100 |  |  |  | IN |  |  |  |  |  |  |  | 0 | 7425 | 742500 | APP |  | 4211 |  | 11 -035 | 12-024F |  | 10-044 |  |  | 11-023 | SC |  |  |  |  |  |  |  |  |  |  |  |
| 14211051d |  | Vend Fab Torus - Torus Vac Vessel Plate-CNC machining (17P7) |  | 206d | 2010-11-01 A | 2011-08-31 A | 14211051c FS-206d | 100% |  |  |  | PROCUREMENT>$50K 69 NO ESCALATION | 100,000 |  | 0 | 100000 | ELOUADRHIRI L | 1 | 1 |  | P | LATIFA E |  |  |  |  | 11-026 |  |  |  |  |  | 100 |  |  |  | IN |  |  |  |  |  |  |  | 0 | 100000 | 10000000 | APP |  | 4211 |  | 11 -035 | 12-024F |  | 10-044 |  |  | 11-023 | SC |  |  |  |  |  |  |  |  |  |  |  |
| 14211051f |  | Vend Fab Torus - Torus Coil Hub&Machining (17P8) |  | 309d | 2010-11-01 A | 2012-02-06 A | 14211051d FS-206d | 100% |  |  |  | PROCUREMENT>$50K 69 NO ESCALATION | 12,260 |  | 0 | 12260 | ELOUADRHIRI L | 1 | 1 |  | P | LATIFA E |  |  |  |  | 11-026 |  |  |  |  |  | 100 |  |  |  | IN |  |  |  |  |  |  |  | 0 | 12260 | 1226000 | APP |  | 4211 |  | 11 -035 | 12-024F |  | 10-044 |  |  | 11-023 | SC |  |  |  |  |  |  |  |  |  |  |  |
| 14211051g |  | Vend Fab Torus - Cryogenic Control Valves (17P9) |  | 309d | 2010-11-01 A | 2012-02-06 A | 14211051f FS-206d | 100% |  |  |  | PROCUREMENT>$50K 69 NO ESCALATION | 40,000 |  | 0 | 40000 | ELOUADRHIRI L | 1 | 1 |  | P | LATIFA E |  |  |  |  | 11-026 |  |  |  |  |  | 100 |  |  |  | IN |  |  |  |  |  |  |  | 0 | 40000 | 4000000 | APP |  | 4211 |  | 11 -035 | 12-024F |  | 10-044 |  |  | 11-023 | SC |  |  |  |  |  |  |  |  |  |  |  |
| 14211051h |  | Vend Fab Torus - Current Leads (17P10) |  | 100d | 2010-11-01 A | 2011-04-01 A | 14211051g FS-206d | 100% |  |  |  | PROCUREMENT>$50K 69 NO ESCALATION | 30,000 |  | 0 | 30000 | ELOUADRHIRI L | 1 | 1 |  | P | LATIFA E |  |  |  |  | 11-026 |  |  |  |  |  | 100 |  |  |  | IN |  |  |  |  |  |  |  | 0 | 30000 | 3000000 | APP |  | 4211 |  | 11 -035 | 12-024F |  | 10-044 |  |  | 11-023 | SC |  |  |  |  |  |  |  |  |  |  |  |
| 14211051j |  | Vend Fab Torus - Instrumentation Sensors (17P11) |  | 309d | 2010-11-01 A | 2012-02-06 A | 14211051h FS-206d | 100% |  |  |  | PROCUREMENT>$50K 69 NO ESCALATION | 50,000 |  | 0 | 50000 | ELOUADRHIRI L | 1 | 1 |  | P | LATIFA E |  |  |  |  | 11-026 |  |  |  |  |  | 100 |  |  |  | IN |  |  |  |  |  |  |  | 0 | 50000 | 5000000 | APP |  | 4211 |  | 11 -035 | 12-024F |  | 10-044 |  |  | 11-023 | SC |  |  |  |  |  |  |  |  |  |  |  |
| 14211051k |  | Vend Fab Torus - Dump Switch (17P12) |  | 243d | 2010-11-01 A | 2011-10-24 A | 14211051j FS-206d | 100% |  |  |  | PROCUREMENT>$50K 69 NO ESCALATION | 50,000 |  | 0 | 50000 | ELOUADRHIRI L | 1 | 1 |  | P | LATIFA E |  |  |  |  | 11-026 |  |  |  |  |  | 100 |  |  |  | IN |  |  |  |  |  |  |  | 0 | 50000 | 5000000 | APP |  | 4211 |  | 11 -035 | 12-024F |  | 10-044 |  |  | 11-023 | SC |  |  |  |  |  |  |  |  |  |  |  |
| 14211051n |  | Vend Fab Torus - PLC&Cabinets (17P13) |  | 309d | 2010-11-01 A | 2012-02-06 A | 14211051k FS-206d | 100% |  |  |  | PROCUREMENT>$50K 69 NO ESCALATION | 12,000 |  | 0 | 12000 | ELOUADRHIRI L | 1 | 1 |  | P | LATIFA E |  |  |  |  | 11-026 |  |  |  |  |  | 100 |  |  |  | IN |  |  |  |  |  |  |  | 0 | 12000 | 1200000 | APP |  | 4211 |  | 11 -035 | 12-024F |  | 10-044 |  |  | 11-023 | SC |  |  |  |  |  |  |  |  |  |  |  |
| 14211051o |  | Vend Fab Torus - Cold Mass Suspension Materials (17P14) |  | 163d | 2010-11-01 A | 2011-06-30 A | 14211051n FS-225d | 100% |  |  |  | PROCUREMENT>$50K 69 NO ESCALATION | 50,000 |  | 0 | 50000 | ELOUADRHIRI L | 1 | 1 |  | P | LATIFA E |  |  |  |  | 11-026 |  |  |  |  |  | 100 |  |  |  | IN |  |  |  |  |  |  |  | 0 | 50000 | 5000000 | APP |  | 4211 |  | 11 -035 | 12-024F |  | 10-044 |  |  | 11-023 | SC |  |  |  |  |  |  |  |  |  |  |  |
| 14211065 |  | Vend Fab Torus -Complete and Warm Test Coil #3 (8) |  | 290d | 2010-11-30 A | 2012-02-06 A | 14211060 FS-284d | 100% |  |  |  | PROCUREMENT<$50K 60 NO ESCALATION; PROCUREMENT>$50K 69 NO ESCALATION | 235,000 |  | 0 | 235000 | ELOUADRHIRI L | 1 | 1 |  | P | LATIFA E |  |  |  |  | 11-026 |  |  |  |  |  | 100 |  |  |  | IN |  |  |  |  |  |  |  | 0 | 235000 | 23500000 | APP |  | 4211 | 09-049 | 11 -035 | 12-024 |  | 10-044 |  |  | 11-023 | SC |  |  |  |  |  |  |  |  |  |  |  |
| 14211070 |  | Vend Fab Torus -Complete and Warm Test Coil #4 (9) |  | 290d | 2010-11-30 A | 2012-02-06 A | 14211065 FS-390d | 100% |  |  |  | PROCUREMENT>$50K 69 NO ESCALATION | 235,000 |  | 0 | 235000 | ELOUADRHIRI L | 1 | 1 |  | P | LATIFA E |  |  |  |  | 11-026 |  |  |  |  |  | 100 |  |  |  | IN |  |  |  |  |  |  |  | 0 | 235000 | 23500000 | APP |  | 4211 | 09-049 | 11 -035 | 12-024 |  | 10-044 |  |  | 11-023 | SC |  |  |  |  |  |  |  |  |  |  |  |
| 14211075 |  | Vend Fab Torus -Complete and Warm Test Coil #5 (10) |  | 290d | 2010-11-30 A | 2012-02-06 A | 14211070 FS-432d | 100% |  |  |  | PROCUREMENT>$50K 69 NO ESCALATION | 235,000 |  | 0 | 235000 | ELOUADRHIRI L | 1 | 1 |  | P | LATIFA E |  |  |  |  | 11-026 |  |  |  |  |  | 100 |  |  |  | IN |  |  |  |  |  |  |  | 0 | 235000 | 23500000 | APP |  | 4211 | 09-049 | 11 -035 | 12-024 |  | 10-044 |  |  | 11-023 | SC |  |  |  |  |  |  |  |  |  |  |  |
| 14211080 |  | Vend Fab Torus -Complete and Warm Test Coil #6 (11) |  | 290d | 2010-11-30 A | 2012-02-06 A | 14211075 FS-455d | 100% |  |  |  | PROCUREMENT>$50K 69 NO ESCALATION | 235,000 |  | 0 | 235000 | ELOUADRHIRI L | 1 | 1 |  | P | LATIFA E |  |  |  |  | 11-026 |  |  |  |  |  | 100 |  |  |  | IN |  |  |  |  |  |  |  | 0 | 235000 | 23500000 | APP |  | 4211 | 09-049 | 11 -035 | 12-024 |  | 10-044 |  |  | 11-023 | SC |  |  |  |  |  |  |  |  |  |  |  |
| 14211020 |  | Torus Vend Contract Support Labor FY11 |  | 244.97d | 2011-01-05 A | 2011-12-29 A | 14211010a, 9-110M FS+60d, 14211015a, 14211004A, 14211015, 14211010 | 100% |  |  |  | ELEC ENG [61.39 h]; ELEC TECH [46.04 h]; MECH DES [122.78 h]; MECH ENG [245.55 h]; MECH TECH [306.94 h]; SCIENTIST [92.08 h]; SKLLD TRADE [36.83 h]; ELEC DES [61.39 h] | 52,691.16 | 52,691.16 | 0 | 52303.4812 | ELOUADRHIRI L | 1 | 1 |  | E | LATIFA E |  |  |  |  | 11-026 |  |  |  |  |  |  |  |  |  |  |  |  |  | 100 | 100 |  |  |  |  |  | APP |  | 4211 | 09-049 | 11 -035 |  |  |  | 4 |  |  |  |  | 6.53061224 | 93.46938775 | 12-001 |  |  |  |  |  |  |  |
| 14211020a |  | Torus Vend Contract Support Labor FY12 |  | 245d | 2011-01-05 A | 2011-12-29 A | 14211020 FS-60d | 100% |  |  |  | MECH ENG [74.45 h]; MECH TECH [93.06 h]; SCIENTIST [27.92 h]; SKLLD TRADE [11.17 h]; ELEC DES [18.61 h]; ELEC ENG [18.61 h]; ELEC TECH [13.96 h]; MECH DES [37.22 h] | 15,975.28 | 15,975.28 | 0 | 16363.143 | ELOUADRHIRI L | 1 | 1 |  | E | LATIFA E |  |  |  |  | 11-026 |  |  |  |  |  |  |  |  |  |  |  |  |  | 100 | 100 |  |  |  |  |  | APP |  | 4211 | 09-049 | 11 -035 |  |  |  | 4 |  |  |  |  | 28.07017543 | 71.92982456 | 12-001 |  |  |  |  |  |  |  |
| 14211012E |  | Torus FY12 Travel |  | 247d | 2011-10-03 A | 2012-09-28 A | 14211011E | 100% |  |  |  | TRAVEL | 8,775.04 |  | 0 | 8775.04 | ELOUADRHIRI L | 1 | 1 |  | E | LATIFA E |  |  |  |  |  |  |  |  |  |  |  |  |  |  |  |  |  |  | 100 | 100 | 07-024 |  |  |  |  |  |  |  | 09-049 |  |  |  |  |  |  |  |  |  | 7.69230769 | 92.3076923 |  |  |  |  |  |  |  |  |
| 14211025 |  | Torus Delivery Installtn & Check-out Original Labor FY13 |  | 188.15d | 2012-01-03 A | 2012-09-28 A | 9-120M FS+60d, 14211020, 14211020a | 100% |  |  |  | ELEC ENG [30.53 h]; ELEC TECH [30.53 h]; MECH DES [122.12 h]; MECH ENG [244.24 h]; MECH TECH [457.96 h]; SCIENTIST [30.53 h]; SKLLD TRADE [48.85 h]; MSHOP; ELEC DES [152.65 h] | 162,381.52 | 58,361.96 | 0 | 162381.5246 | ELOUADRHIRI L | 1 | 1 |  | E | LATIFA E |  |  |  |  | 11-026 |  |  |  |  |  |  |  |  |  |  |  |  |  | 100 | 100 |  |  |  |  |  | APP |  | 4211 | 09-049 | 11 -035 |  |  |  | 4 |  |  |  |  | 31.17408906 | 68.82591093 |  | 12-053 |  |  |  |  |  |  |
| 14211085 |  | Reverse Entry per CR12-024 |  | 4d | 2012-02-01 A | 2012-02-06 A | 9-120M FS+80d | 100% |  |  |  | PROCUREMENT<$50K 60 NO ESCALATION; PROCUREMENT>$50K 69 NO ESCALATION | -1,847,553 |  |  |  | ELOUADRHIRI L | 1 | 1 |  | P | LATIFA E |  |  |  |  | 11-026 |  |  |  |  |  | 100 |  |  |  | IN |  |  |  |  |  |  |  |  |  |  | APP |  | 4211 | 09-049 | 11 -035 | 12-024 |  | 10-044 |  |  |  | SC |  |  |  |  |  |  |  |  |  |  |  |
| 14211025a |  | Torus Delivery Installtn & Check-out Original Labor FY13 |  | 58d | 2012-10-01 A | 2012-11-19 A | 14211025 | 100% | 2012-10-01 | 2012-12-21 |  | MECH TECH [142.04 h]; SCIENTIST [9.47 h]; SKLLD TRADE [15.15 h]; MSHOP; ELEC DES [47.35 h]; ELEC ENG [9.47 h]; ELEC TECH [9.47 h]; MECH DES [37.88 h]; MECH ENG [75.76 h] | 51,972.48 | 18,680.56 | 0 | 51972.5015 | ELOUADRHIRI L | 1 | 1 |  | E | LATIFA E |  |  |  |  | 11-026 |  |  |  |  |  |  |  |  |  |  |  |  |  | 100 | 100 |  |  |  |  |  | APP |  | 4211 | 09-049 | 11 -035 |  |  |  | 4 |  |  |  |  | 25.86206896 | 74.13793103 |  | 12-053 |  |  |  |  |  |  |
| 14211095 |  | Re-Baseline Actuals Adjustment |  | 1d | 2013-08-30 A | 2013-08-30 A |  | 100% | 2013-09-03 | 2013-09-03 |  | PROCUREMENT>$50K 69 NO ESCALATION | 512,279.26 |  |  | 512279.26 |  |  |  |  |  |  |  |  |  |  |  |  |  |  |  |  | 100 | ADJ |  |  |  |  |  |  |  |  |  |  | 0 | 512279.26 | 51227926 |  |  |  |  |  |  |  |  |  |  |  |  |  |  |  |  |  |  |  |  |  |  |  |
| 24211090 |  | Wang Torus Settlement |  | 20d | 2013-09-03 A | 2013-09-16 A | 9-130M FS+228d | 100% | 2013-10-01 | 2013-10-28 | 8/5 M-F w/JLAB Holidays ReBaseline | PROCUREMENT<$50K 60 NO ESCALATION; PROCUREMENT>$50K 69 NO ESCALATION | 217,517.77 |  |  | 0 | ELOUADRHIRI L | 1 | 1 |  | D | LATIFA E |  |  |  |  | 11-026 |  |  |  |  |  | 100 |  |  | 24211090 | IN |  | 13-015 | PR |  |  |  |  | 0 | 217517.77 | 21751777 | APP |  | 4211 | 09-049 | 11 -035 | 12-024 |  | 10-044 |  |  |  | SC |  |  |  |  |  | 217517.76 | 12-055 | 13-002F | OB | OB |  |
| 24211095 |  | Wang Torus Settlement Final |  | 20d | 2013-09-03 A | 2013-09-16 A | 9-130M FS+228d | 100% | 2013-10-01 | 2013-10-28 | 8/5 M-F w/JLAB Holidays ReBaseline | PROCUREMENT<$50K 60 NO ESCALATION; PROCUREMENT>$50K 69 NO ESCALATION | 421,264.48 |  |  | 0 | ELOUADRHIRI L | 1 | 1 |  | D | LATIFA E |  |  |  |  | 11-026 |  |  |  |  |  | 100 |  |  | 24211090 | IN |  | 13-015 | PR |  |  |  |  | 0 | 421264.48 | 42126448 | APP |  | 4211 | 09-049 | 11 -035 | 12-024 |  | 10-044 |  |  |  | SC |  |  |  |  |  | 421264.48 | 12-055 | 13-002F | OB | OB-2 | 13-016 |

Notes:
- 14211004: Steps: SSR (done); PDR (done); Vendor Meeting (done); IDR 90% (done); IDR 10% (done)
- 14211004A: Steps: SSR (done); PDR (done); Vendor Meeting (done); IDR 90% (done); IDR 10% (done)
- 14211004B: Steps: SSR (done); PDR (done); Vendor Meeting (done); IDR 90% (done); IDR 10% (done)
- 14211040C: Steps: Solder Prototype (done); Solder Coil 1 (done); Solder Coil 2 (done); Solder Coil 3 (done); Solder Coil 4 (done); Solder Coil 5 (done); Solder Coil 6 (done)
- 14211050: Explanation: Phase 2 of award / Steps: Winding (done); Epoxy potting (done); Case closure and welding (done)
- 14211055: Explanation: Phase 2 of award
- 14211060: Explanation: Phase 2 of award
- 14211040B: Steps: Copper Channel (done); Soldering line development (done); Solder Stabilizer Test Run (done)
- 14211045C: Steps: Initial Review (done); First Response to ? (done); Final Response to ? (done)
- 14211045D: Steps: QA review (done); Phase 1 Demonstrate Prototype winding (done); After Prototype manufacture (done); Update procedures (done); Final Drawing Package (done); Change control procedures (done)
- 14211050A: Steps: Prototype test (done); Prototype Cryostat Assembly (done)

| ID | WBS | Activity | Duration | Start | Finish | Predecessors | Complete | Planned start | Planned finish | Calendar | Resources | Cost | Actual cost | LOE Divider | LOE Multiplier | Calculated Remaining Total Cost | MONTHLY EV COST | RESP - Responsibility | STRT%COMP for CM EVM | FNSH%COMP for CM EVM | CR 07-024 | EVMS Reporting Codes | CAM RESPONSIBLE | CR 08-058 | CR 11-005 | CR 11-026 | CR 11-035 | Advance Purchase Plan > 500K | CR 08-016 | 12 GEV MAJOR PROCUREMENT CATAGORY | Activities with Steps | CR 09-012 | CR 10-001 | Remaining Material Cost Based on % Compl | Claimed Material Cost Based on % Complet | Initial Claimed Material Calc | Claimed Material Divider | CR 10-005 | CR 11-022 | CR 12-024 | CR 10-044 | Schedule Contingency | CR 11-022a | CR 08-052 | CR 11-001 | LOE % Pre Calc | LOE % | CR 08-039 | CR 12-001 | Installation | ReBaseline Actuals Adjustment | Original Activity ID Rebaseline | PRIOR MONTH EV COST | CR 12-055 | CR 13-002 | BOE Procurement | CR 13-015 | Post Rebaseline | Obligated Prior to Rebaseline | PHAS - Project Phase | CR 09-049 | CR 13-016 |
| --- | --- | --- | --- | --- | --- | --- | --- | --- | --- | --- | --- | --- | --- | --- | --- | --- | --- | --- | --- | --- | --- | --- | --- | --- | --- | --- | --- | --- | --- | --- | --- | --- | --- | --- | --- | --- | --- | --- | --- | --- | --- | --- | --- | --- | --- | --- | --- | --- | --- | --- | --- | --- | --- | --- | --- | --- | --- | --- | --- | --- | --- | --- |
|  | 2 | **1.4.2.1.2 SOLENOID** |  | 2009-01-02 | 2013-09-16 |  |  |  |  |  |  |  |  |  |  |  |  |  |  |  |  |  |  |  |  |  |  |  |  |  |  |  |  |  |  |  |  |  |  |  |  |  |  |  |  |  |  |  |  |  |  |  |  |  |  |  |  |  |  |  |  |  |
| 14212009E |  | Solenoid FY09 Travel | 189d | 2009-01-02 A | 2009-09-30 A | 14212009EX | 100% |  |  |  | TRAVEL | 6,086.21 |  | 100 | 100 | 0 | 6086.208114 | ELOUADRHIRI L | 1 | 1 | 07-024 | E | LATIFA E | 08-058 | 11-005 | 11-026 | 11 -035 |  |  |  |  |  |  |  |  |  |  |  |  |  |  |  |  |  |  |  |  |  |  |  |  |  |  |  |  |  |  |  |  |  |  |  |
| 14212010E |  | Solenoid FY10 Travel | 248d | 2009-10-01 A | 2010-09-30 A | 14212009E | 100% |  |  |  | TRAVEL | 8,240.89 |  | 100 | 100 | 0 | 8240.887547 | ELOUADRHIRI L | 1 | 1 | 07-024 | E | LATIFA E |  | 11-005 | 11-026 | 11 -035 |  |  |  |  |  |  |  |  |  |  |  |  |  |  |  |  |  |  |  |  |  |  |  |  |  |  |  |  |  |  |  |  |  |  |  |
| 14212005 |  | Solenoid Vend Comp Dsgn Labor FY09 | 212d | 2009-11-20 A | 2010-09-30 A | 14212002X | 100% |  |  |  | SCIENTIST [15.35 h]; OFFICE [30.69 h]; MECH DES [61.39 h]; MECH TECH [245.55 h]; ELEC ENG [15.35 h]; ELEC TECH [15.35 h]; VISTNG USERS [92.08 h]; MECH ENG [61.39 h] | 22,234.48 | 22,234.48 |  |  | 0 | 21547.0754 | ELOUADRHIRI L | 1 | 1 |  | S | LATIFA E |  | 11-005 | 11-026 | 11 -035 | APP | 08-016 | 4212 | ST | 09-012 | 10-001B |  |  |  |  |  |  |  |  |  |  |  |  |  |  |  |  |  |  |  |  |  |  |  |  |  |  |  |  |  |
| 14212005b |  | Solenoid Vend Comp Dsgn Labor FY10 | 212d | 2009-11-20 A | 2010-09-30 A | 14212005 FS-250d | 100% |  |  |  | MECH DES [18.61 h]; MECH TECH [74.45 h]; ELEC ENG [4.65 h]; ELEC TECH [4.65 h]; VISTNG USERS [27.92 h]; MECH ENG [18.61 h]; OFFICE [9.31 h]; SCIENTIST [4.65 h] | 6,740.52 | 6,740.52 |  |  | 0 | 6740.5165 | ELOUADRHIRI L | 1 | 1 |  | S | LATIFA E |  | 11-005 | 11-026 | 11 -035 | APP |  | 4212 | ST |  | 10-001B |  |  |  |  |  |  |  |  |  |  |  |  |  |  |  |  |  |  |  |  |  |  |  |  |  |  |  |  |  |
| 14212005c |  | Vend Fab Solenoid Peg Point #1 Completion of System Requirements Review (SSR) | 33d | 2009-11-20 A | 2010-01-18 A | 14212002X FS+1d, 9-100M FS+36d | 100% | 2009-11-20 | 2010-01-15 |  | PROCUREMENT>$50K 69 NO ESCALATION; PROCUREMENT<$50K 60 NO ESCALATION | 100,000 |  |  |  | 0 | 100000 | ELOUADRHIRI L | 1 | 1 |  | P | LATIFA E |  |  | 11-026 | 11 -035 | APP |  | 4212 |  |  | 10-001B | 0 | 100000 | 10000000 | 100 | 10-005 | 11-022 | 12-024F |  |  |  |  |  |  |  |  |  |  |  |  |  |  |  |  |  |  |  |  |  |  |
| 14212005d |  | Vend Fab Solenoid Peg Point #2 Completion of Preliminary Design Review | 62d | 2009-11-20 A | 2010-03-01 A | 14212005c FS-22d | 100% |  |  |  | PROCUREMENT>$50K 69 NO ESCALATION | 100,000 |  |  |  | 0 | 100000 | ELOUADRHIRI L | 1 | 1 |  | P | LATIFA E |  |  | 11-026 | 11 -035 | APP |  | 4212 |  |  |  | 0 | 100000 | 10000000 | 100 | 10-005 | 11-022 | 12-024F |  |  |  |  |  |  |  |  |  |  |  |  |  |  |  |  |  |  |  |  |  |  |
| 14212005f |  | Vend Fab Solenoid Peg Point #3 Design, Construction and Testing of Prototype Testcoil | 542d | 2009-11-20 A | 2012-02-06 A | 14212005dA FS-62d, 14212005d FS-61d, 14212005dB FS-193d | 100% |  |  |  | PROCUREMENT>$50K 69 NO ESCALATION | 200,000 |  |  |  | 0 | 200000 | ELOUADRHIRI L | 1 | 1 |  | D | LATIFA E |  |  | 11-026 | 11 -035 | APP |  | 4212 |  |  |  | 0 | 200000 | 20000000 | 100 | 10-005 | 11-022 | 12-024F | 10-044 |  |  |  |  |  |  |  |  |  |  |  |  |  |  |  |  |  |  |  |  |  |
| 14212005g |  | Vend Fab Solenoid Peg Point #4 Intermediate Design Review | 212d | 2009-11-20 A | 2010-09-30 A | 14212005f FS-253d | 100% |  |  |  | PROCUREMENT>$50K 69 NO ESCALATION | 200,000 |  |  |  | 0 | 200000 | ELOUADRHIRI L | 1 | 1 |  | P | LATIFA E |  |  | 11-026 | 11 -035 | APP |  | 4212 |  |  |  | 0 | 200000 | 20000000 | 100 | 10-005 | 11-022 | 12-024F | 10-044 |  |  |  |  |  |  |  |  |  |  |  |  |  |  |  |  |  |  |  |  |  |
| 14212005h |  | Vend Fab Solenoid Peg Point #5 Final Design Review | 369d | 2009-11-20 A | 2011-05-23 A | 14212005g FS-270d | 100% |  |  |  | PROCUREMENT>$50K 69 NO ESCALATION | 200,000 |  |  |  | 0 | 200000 | ELOUADRHIRI L | 1 | 1 |  | S | LATIFA E |  |  | 11-026 | 11 -035 | APP |  | 4212 | ST |  |  | 0 | 200000 | 20000000 | 100 | 10-005 | 11-022 | 12-024F | 10-044 |  |  |  |  |  |  |  |  |  |  |  |  |  |  |  |  |  |  |  |  |  |
| 14212005j |  | Vend Fab Solenoid Peg Point #6A Manufacturing Readiness Review Phase 1 | 542d | 2009-11-20 A | 2012-02-06 A | 14212005h FS-309d | 100% |  |  |  | PROCUREMENT>$50K 69 NO ESCALATION | 25,000 |  |  |  | 0 | 25000 | ELOUADRHIRI L | 1 | 1 |  | P | LATIFA E |  |  | 11-026 | 11 -035 | APP |  | 4212 |  |  |  | 0 | 25000 | 2500000 | 100 | 10-005 | 11-022 | 12-024F | 10-044 |  |  |  |  |  |  |  |  |  |  |  |  |  |  |  |  |  |  |  |  |  |
| 14212005jA |  | Vend Fab Solenoid Peg Point #6B Manufacturing Readiness Review Phase 2 | 542d | 2009-11-20 A | 2012-02-06 A | 14212005j FS-373d | 100% |  |  |  | PROCUREMENT>$50K 69 NO ESCALATION | 25,000 |  |  |  | 0 | 25000 | ELOUADRHIRI L | 1 | 1 |  | P | LATIFA E |  |  | 11-026 | 11 -035 | APP |  | 4212 |  |  |  | 0 | 25000 | 2500000 | 100 | 10-005 | 11-022 | 12-024F | 10-044 | SC |  |  |  |  |  |  |  |  |  |  |  |  |  |  |  |  |  |  |  |  |
| 14212005k |  | Vend Fab Solenoid Peg Point #7 Complete Winding & Coil Assembly of First set coils (1 to 6 modules) | 542d | 2009-11-20 A | 2012-02-06 A | 14212005jA FS-416d | 100% |  |  |  | PROCUREMENT>$50K 69 NO ESCALATION | 50,000 |  |  |  | 0 | 50000 | ELOUADRHIRI L | 1 | 1 |  | P | LATIFA E |  |  | 11-026 | 11 -035 | APP |  | 4212 |  |  |  | 0 | 50000 | 5000000 | 100 | 10-005 | 11-022 | 12-024F | 10-044 |  |  |  |  |  |  |  |  |  |  |  |  |  |  |  |  |  |  |  |  |  |
| 14212005kA |  | Vend Fab Solenoid Peg Point #18 Miscellaneous Materials Procurements Phase 1 | 542d | 2009-11-20 A | 2012-02-06 A | 14212005k FS-557d | 100% |  |  |  | PROCUREMENT>$50K 69 NO ESCALATION | 100,000 |  |  |  | 0 | 100000 | ELOUADRHIRI L | 1 | 1 |  | S | LATIFA E |  |  | 11-026 | 11 -035 | APP |  | 4212 | ST |  |  | 0 | 100000 | 10000000 | 100 | 10-005 | 11-022 | 12-024F | 10-044 | SC | 11-022a |  |  |  |  |  |  |  |  |  |  |  |  |  |  |  |  |  |  |  |
| 14212007 |  | Solenoid Vend Comp Dsgn & Prcrmnt Original Labor FY10 | 246d | 2010-01-01 A | 2010-09-30 A | 9-100M, 14212005b FS-250d | 100% | 2010-01-04 | 2010-12-29 |  | MECH DES [61.61 h]; ELEC ENG [15.4 h]; ELEC TECH [15.4 h]; VISTNG USERS [92.42 h]; SCIENTIST [15.4 h]; OFFICE [30.81 h]; MECH ENG [61.61 h]; MECH TECH [246.45 h] | 22,479.43 | 22,314.58 | 100 | 100 | 0 | 22314.577246 | ELOUADRHIRI L | 1 | 1 |  | E | LATIFA E |  | 11-005 | 11-026 | 11 -035 | APP |  | 4212 |  | 09-012 |  |  |  |  |  | 10-005 |  |  |  |  |  | 08-052 | 11-001 |  |  |  |  |  |  |  |  |  |  |  |  |  |  |  |  |  |
| 14212007a |  | Solenoid Vend Comp Dsgn & Prcrmnt Original Labor FY11 | 246d | 2010-01-01 A | 2010-12-29 A | 14212005b FS-250d, 9-100M | 100% | 2010-01-04 | 2010-12-29 |  | ELEC TECH [4.6 h]; VISTNG USERS [27.58 h]; SCIENTIST [4.6 h]; OFFICE [9.19 h]; MECH ENG [18.39 h]; MECH DES [18.39 h]; MECH TECH [73.55 h]; ELEC ENG [4.6 h] | 6,709.63 | 6,709.63 | 100 | 100 | 0 | 6872.7729 | ELOUADRHIRI L | 1 | 1 |  | E | LATIFA E |  | 11-005 | 11-026 | 11 -035 | APP |  | 4212 |  | 09-012 |  |  |  |  |  | 10-005 |  |  |  |  |  | 08-052 | 11-001 |  |  |  |  |  |  |  |  |  |  |  |  |  |  |  |  |  |
| 14212005dA |  | Vend Fab Solenoid Peg Point #2 Completion of Preliminary Design Review Reverse Entry per CR10-044 | 1d | 2010-03-01 A | 2010-03-01 A | 9-100M FS+97d | 100% |  |  |  | PROCUREMENT>$50K 69 NO ESCALATION | -100,000 |  |  |  |  |  | ELOUADRHIRI L | 1 | 1 |  | P | LATIFA E |  |  | 11-026 | 11 -035 | APP |  | 4212 |  |  |  |  |  |  | 100 |  | 11-022 | 12-024F | 10-044 |  |  |  |  |  |  |  |  |  |  |  |  |  |  |  |  |  |  |  |  |  |
| 14212005dB |  | Vend Fab Solenoid Peg Point #2 Completion of Preliminary Design Review Revised Delivery per CR10-044 | 61d | 2010-03-01 A | 2010-05-24 A | 9-100M FS+97d | 100% |  |  |  | PROCUREMENT>$50K 69 NO ESCALATION | 100,000 |  |  |  | 0 | 100000 | ELOUADRHIRI L | 1 | 1 |  | P | LATIFA E |  |  | 11-026 | 11 -035 | APP |  | 4212 |  |  |  | 0 | 100000 | 10000000 | 100 |  | 11-022 | 12-024F | 10-044 |  |  |  |  |  |  |  |  |  |  |  |  |  |  |  |  |  |  |  |  |  |
| 14212011E |  | Solenoid FY11 Travel | 248d | 2010-10-01 A | 2011-09-30 A | 14212010E | 100% |  |  |  | TRAVEL | 8,503.77 |  | 100 | 100 | 0 | 8503.77 | ELOUADRHIRI L | 1 | 1 | 07-024 | E | LATIFA E |  | 11-005 | 11-026 | 11 -035 |  |  |  |  |  |  |  |  |  |  |  |  |  |  |  |  |  |  | 8.46774193 | 91.53225806 |  |  |  |  |  |  |  |  |  |  |  |  |  |  |  |
| 14212005n |  | Vend Fab Solenoid Peg Point #8 Mid-Term Manufacturing Progress Review | 279d | 2010-12-15 A | 2012-02-06 A | 14212005kA5 FS-149d, 14212005kA FS-149d | 100% |  |  |  | PROCUREMENT>$50K 69 NO ESCALATION | 48,790 |  |  |  | 0 | 48790 | ELOUADRHIRI L | 1 | 1 |  | P | LATIFA E |  |  | 11-026 | 11 -035 | APP |  | 4212 |  |  |  | 0 | 48790 | 4879000 | 100 | 10-005 | 11-022 | 12-024 | 10-044 |  |  |  |  |  |  |  |  |  |  |  |  |  |  |  |  |  |  |  |  |  |
| 14212005o |  | Vend Fab Solenoid Peg Point #9 Complete Winding & Coil Assembly of Second set coils (7 to 12 modules) | 279d | 2010-12-15 A | 2012-02-06 A | 14212005n FS-290d | 100% |  |  |  | PROCUREMENT>$50K 69 NO ESCALATION | 50,000 |  |  |  | 0 | 50000 | ELOUADRHIRI L | 1 | 1 |  | P | LATIFA E |  |  | 11-026 | 11 -035 | APP |  | 4212 |  |  |  | 0 | 50000 | 5000000 | 100 | 10-005 | 11-022 | 12-024 | 10-044 |  |  |  |  |  |  |  |  |  |  |  |  |  |  |  |  |  |  |  |  |  |
| 14212005p |  | Vend Fab Solenoid Peg Point #10 Complete Winding & Coil Assembly of Third set coils (13 to 19 modules) | 279d | 2010-12-15 A | 2012-02-06 A | 14212005o FS-398d | 100% |  |  |  | PROCUREMENT>$50K 69 NO ESCALATION | 50,000 |  |  |  | 0 | 50000 | ELOUADRHIRI L | 1 | 1 |  | P | LATIFA E |  |  | 11-026 | 11 -035 | APP |  | 4212 |  |  |  | 0 | 50000 | 5000000 | 100 | 10-005 | 11-022 | 12-024 | 10-044 |  |  |  |  |  |  |  |  |  |  |  |  |  |  |  |  |  |  |  |  |  |
| 14212005q |  | Vend Fab Solenoid Peg Point #11 Complete Instrumentation and Control | 279d | 2010-12-15 A | 2012-02-06 A | 14212005p FS-516d | 100% |  |  |  | PROCUREMENT>$50K 69 NO ESCALATION | 80,000 |  |  |  | 0 | 80000 | ELOUADRHIRI L | 1 | 1 |  | P | LATIFA E |  |  | 11-026 | 11 -035 | APP |  | 4212 |  |  |  | 0 | 80000 | 8000000 | 100 | 10-005 | 11-022 | 12-024 | 10-044 |  |  |  |  |  |  |  |  |  |  |  |  |  |  |  |  |  |  |  |  |  |
| 14212005r |  | Vend Fab Solenoid Peg Point #12 Complete Subcontractor Acceptance Test Readiness Review | 279d | 2010-12-15 A | 2012-02-06 A | 14212005q FS-375d | 100% |  |  |  | PROCUREMENT>$50K 69 NO ESCALATION | 50,000 |  |  |  | 0 | 50000 | ELOUADRHIRI L | 1 | 1 |  | P | LATIFA E |  |  | 11-026 | 11 -035 | APP |  | 4212 |  |  |  | 0 | 50000 | 5000000 | 100 | 10-005 | 11-022 | 12-024 | 10-044 |  |  |  |  |  |  |  |  |  |  |  |  |  |  |  |  |  |  |  |  |  |
| 14212005s |  | Vend Fab Solenoid Peg Point #13 Complete Cryogenic Reservoir Subassembly Phase 1 | 279d | 2010-12-15 A | 2012-02-06 A | 14212005r FS-348d | 100% |  |  |  | PROCUREMENT>$50K 69 NO ESCALATION | 69,000 |  |  |  | 0 | 69000 | ELOUADRHIRI L | 1 | 1 |  | P | LATIFA E |  |  | 11-026 | 11 -035 | APP |  | 4212 |  |  |  | 0 | 69000 | 6900000 | 100 | 10-005 | 11-022 | 12-024 | 10-044 |  |  |  |  |  |  |  |  |  |  |  |  |  |  |  |  |  |  |  |  |  |
| 14212010 |  | Solenoid Vend Coil Winding Original Labor FY11 | 248d | 2010-12-30 A | 2011-12-29 A | 14212007a, 14212007 | 100% |  |  |  | ELEC ENG [30.81 h]; MECH DES [92.42 h]; MECH TECH [308.06 h]; VISTNG USERS [92.42 h]; SCIENTIST [46.21 h]; MECH ENG [92.42 h] | 31,088.3 | 31,088.3 | 100 | 100 | 0 | 30862.2135 | ELOUADRHIRI L | 1 | 1 |  | E | LATIFA E |  | 11-005 | 11-026 | 11 -035 | APP |  | 4212 |  | 09-012 |  |  |  |  |  | 10-005 |  |  |  |  |  | 08-052 |  | 8.37696335 | 91.62303664 | 08-039 | 12-001 |  |  |  |  |  |  |  |  |  |  |  |  |  |
| 14212010a |  | Solenoid Vend Coil Winding Original Labor FY12 | 248d | 2010-12-30 A | 2011-12-29 A | 14212010 FS-60d | 100% |  |  |  | MECH DES [27.58 h]; MECH ENG [27.58 h]; VISTNG USERS [27.58 h]; ELEC ENG [9.19 h]; MECH TECH [91.94 h]; SCIENTIST [13.79 h] | 9,277.47 | 9,277.47 | 100 | 100 | 0 | 9503.5315 | ELOUADRHIRI L | 1 | 1 |  | E | LATIFA E |  | 11-005 | 11-026 | 11 -035 | APP |  | 4212 |  | 09-012 |  |  |  |  |  | 10-005 |  |  |  |  |  | 08-052 |  | 28.07017543 | 71.92982456 | 08-039 | 12-001 |  |  |  |  |  |  |  |  |  |  |  |  |  |
| 14212015 |  | Solenoid Vend Compnts Fab Original Labor FY11 | 248d | 2010-12-30 A | 2011-12-29 A | 14212007a, 14212007 | 100% |  |  |  | ELEC TECH [15.4 h]; VISTNG USERS [92.42 h]; SCIENTIST [15.4 h]; MECH ENG [61.61 h]; MECH DES [61.61 h]; MECH TECH [308.06 h]; ELEC ENG [15.4 h] | 25,008.88 | 25,008.88 | 100 | 100 | 0 | 24827.05529 | ELOUADRHIRI L | 1 | 1 |  | E | LATIFA E |  | 11-005 | 11-026 | 11 -035 | APP |  | 4212 |  | 09-012 |  |  |  |  |  | 10-005 |  |  |  |  |  | 08-052 |  | 6.4516129 | 93.54838709 |  | 12-001 |  |  |  |  |  |  |  |  |  |  |  |  |  |
| 14212015a |  | Solenoid Vend Compnts Fab Original Labor FY12 | 248d | 2010-12-30 A | 2011-12-29 A | 14212015 FS-60d | 100% |  |  |  | VISTNG USERS [27.58 h]; MECH TECH [91.94 h]; ELEC ENG [4.6 h]; MECH DES [18.39 h]; ELEC TECH [4.6 h]; SCIENTIST [4.6 h]; MECH ENG [18.39 h] | 7,464.81 | 7,464.81 | 100 | 100 | 0 | 7646.6681 | ELOUADRHIRI L | 1 | 1 |  | E | LATIFA E |  | 11-005 | 11-026 | 11 -035 | APP |  | 4212 |  | 09-012 |  |  |  |  |  | 10-005 |  |  |  |  |  | 08-052 |  | 28.07017543 | 71.92982456 |  | 12-001 |  |  |  |  |  |  |  |  |  |  |  |  |  |
| 14212005kA5 |  | Vend Fab Solenoid Peg Point #18a Miscellaneous Materials Procurements Phase 2 | 252d | 2011-02-01 A | 2012-02-06 A | 14212005kA FS-149d | 100% |  |  |  | PROCUREMENT>$50K 69 NO ESCALATION; PROCUREMENT<$50K 60 NO ESCALATION | 452,210 |  |  |  | 0 | 452210 | ELOUADRHIRI L | 1 | 1 |  | S | LATIFA E |  |  | 11-026 | 11 -035 | APP |  | 4212 | ST |  |  | 0 | 452210 | 45221000 | 100 | 10-005 | 11-022 | 12-024F | 10-044 | SC | 11-022a |  |  |  |  |  |  |  |  |  |  |  |  |  |  |  |  |  |  |  |
| 14212012E |  | Solenoid FY12 Travel | 228d | 2011-10-03 A | 2012-08-31 A | 14212011E | 100% |  |  |  | TRAVEL | 8,775.04 |  | 100 | 100 | 0 | 8775.04 | ELOUADRHIRI L | 1 | 1 | 07-024 | E | LATIFA E |  | 11-005 | 11-026 | 11 -035 |  |  |  |  |  |  |  |  |  |  | 10-005 |  |  |  |  |  |  |  | 10.08771929 | 89.9122807 |  |  |  |  |  |  |  |  |  |  |  |  |  |  |  |
| 14212020 |  | Solenoid Vend Assy & Testing Original Labor | 61d | 2011-11-23 A | 2012-02-29 A | 14212010 FS-20d, 14212010a FS-20d, 14212015a FS-20d, 9-120M FS+22d | 100% |  |  |  | MECH TECH [480 h]; ELEC ENG [20 h]; ELEC TECH [40 h]; VISTNG USERS [120 h]; SCIENTIST [40 h]; MECH ENG [120 h]; MECH DES [120 h] | 43,846.4 | 43,846.4 | 100 | 100 | 0 | 43846.4 | ELOUADRHIRI L | 1 | 1 |  | E | LATIFA E |  | 11-005 | 11-026 | 11 -035 | APP |  | 4212 |  | 09-012 |  |  |  |  |  | 10-005 |  |  |  |  |  | 08-052 |  | 32.78688524 | 67.21311475 |  |  |  |  |  |  |  |  |  |  |  |  |  |  |  |
| 14212005sA |  | Reverse Entry per CR12-024 | 4d | 2012-02-01 A | 2012-02-06 A | 9-120M FS+80d | 100% |  |  |  | PROCUREMENT<$50K 60 NO ESCALATION; PROCUREMENT>$50K 69 NO ESCALATION | -808,277.32 |  |  |  |  |  | ELOUADRHIRI L | 1 | 1 |  | P | LATIFA E |  |  | 11-026 | 11 -035 | APP |  | 4212 |  |  |  |  |  |  | 100 | 10-005 | 11-022 | 12-024 | 10-044 | SC |  |  |  |  |  |  |  |  |  |  |  |  |  |  |  |  |  |  |  |  |
| 14212025 |  | Solenoid Delivery & Qualification Check-out Original Labor | 130d | 2012-03-01 A | 2012-08-31 A | 14212020 | 100% |  |  |  | ELEC ENG [20 h]; MECH ENG [120 h]; MECH DES [120 h]; MECH TECH [480 h]; ELEC TECH [40 h]; VISTNG USERS [120 h]; MSHOP | 74,460.77 | 41,022 | 100 | 100 | 0 | 74460.77 | ELOUADRHIRI L | 1 | 1 |  | E | LATIFA E |  | 11-005 | 11-026 | 11 -035 | APP | 08-016 | 4212 |  | 09-012 |  |  |  |  |  | 10-005 |  |  |  |  |  | 08-052 |  | 17.69230769 | 82.3076923 |  |  | Install |  |  |  |  |  |  |  |  |  |  |  |  |
| 14212030 |  | Re-Baseline Actuals Adjustment | 1d | 2013-08-30 A | 2013-08-30 A |  | 100% | 2013-09-03 | 2013-09-03 |  | PROCUREMENT>$50K 69 NO ESCALATION | 307,509.11 |  |  |  |  | 307509.11 |  |  |  |  |  |  |  |  |  |  |  |  |  |  |  |  | 0 | 307509.11 | 30750911 | 100 |  |  |  |  |  |  |  |  |  |  |  |  |  | ADJ |  |  |  |  |  |  |  |  |  |  |  |
| 24212000 |  | Wang Solenoid Settlement | 20d | 2013-09-03 A | 2013-09-16 A | 9-130M FS+228d | 100% | 2013-10-01 | 2013-10-28 | 8/5 M-F w/JLAB Holidays ReBaseline | PROCUREMENT>$50K 69 NO ESCALATION | 36,924.5 |  |  |  |  | 0 | ELOUADRHIRI L | 1 | 1 |  | D | LATIFA E |  |  | 11-026 | 11 -035 | APP |  | 4212 |  |  |  | 0 | 36924.5 | 3692450 | 100 | 10-005 | 11-022 | 12-024 | 10-044 | SC |  |  |  |  |  |  |  |  |  | 24212005t | 36924.5 | 12-055 | 13-002F | OB | 13-015 | PR | OB |  |  |  |
| 24212005 |  | Wang Solenoid Settlement Final | 20d | 2013-09-03 A | 2013-09-16 A | 9-130M FS+228d | 100% | 2013-10-01 | 2013-10-28 | 8/5 M-F w/JLAB Holidays ReBaseline | PROCUREMENT<$50K 60 NO ESCALATION; PROCUREMENT>$50K 69 NO ESCALATION | 286,075.5 |  |  |  |  | 0 | ELOUADRHIRI L | 1 | 1 |  | D | LATIFA E |  |  | 11-026 | 11 -035 | APP |  | 4211 |  |  |  | 0 | 286075.5 | 28607550 | 100 |  |  | 12-024 | 10-044 | SC |  |  |  |  |  |  |  |  |  | 24211090 | 286075.5 | 12-055 | 13-002F | OB | 13-015 | PR | OB-2 | IN | 09-049 | 13-016 |

Notes:
- 14212005: Steps: SSR (done); PDR (done); March 16 Vendor Meeting (done); IDR (done)
- 14212005b: Steps: SSR (done); PDR (done); March 16 Vendor Meeting (done); IDR (done)
- 14212005h: Steps: Initial Review (done); First Response to ? (done); Final Response to ? (done)
- 14212005k: Steps: Solder Conductor; others TBD
- 14212005kA: Steps: Steps moved from 14212005kA5 (done)
- 14212005kA5: Steps: OFHC Stabilizer (done); Coil Case Plate-Mill run (done); Coil Case Plates-CNC machining (done); Epoxy (done); Solenoid Vac Vessel Plate-Mill run $ reside in 14212005f $30k (done); Solenoid Vac Vessel Plate-CNC machining (done); Cryogenic Control Valves $ reside in 14212005f $40k (done); Current Leads (done); Instrumentation Sensors $ reside in 14212005f $50k (done); Dump Switch (done); PLC&Cabinets (done); Cold Mass Suspension Materials (done)

| ID | WBS | Activity | Type | Duration | Start | Finish | Predecessors | Complete | Planned start | Planned finish | Resources | Cost | Actual cost | LOE Divider | LOE Multiplier | Calculated Remaining Total Cost | MONTHLY EV COST | RESP - Responsibility | STRT%COMP for CM EVM | FNSH%COMP for CM EVM | CR 07-024 | EVMS Reporting Codes | CAM RESPONSIBLE | CR 11-005 | CR 11-026 | CR 11-035 | CR 12-013 | Advance Purchase Plan > 500K | CR 08-016 | 12 GEV MAJOR PROCUREMENT CATAGORY | CR 09-012 | CR 11-001 | LOE % Pre Calc | LOE % | Remaining Material Cost Based on % Compl | Claimed Material Cost Based on % Complet | Initial Claimed Material Calc | Claimed Material Divider | CR 10-060 | CR 11-013 | Phil Dev | CR 11-024 | Pat's Code | SVT | CR 11-058 | Profile change | CR 12-054 | OPC Allison | MARCH!!! | CR 12-001 | CR 12-027 | CR 12-053 | Activities with Steps |
| --- | --- | --- | --- | --- | --- | --- | --- | --- | --- | --- | --- | --- | --- | --- | --- | --- | --- | --- | --- | --- | --- | --- | --- | --- | --- | --- | --- | --- | --- | --- | --- | --- | --- | --- | --- | --- | --- | --- | --- | --- | --- | --- | --- | --- | --- | --- | --- | --- | --- | --- | --- | --- | --- |
|  | 2 | **1.4.2.2 DETECTORS** |  |  | 2009-01-02 | 2015-08-04 |  |  |  |  |  |  |  |  |  |  |  |  |  |  |  |  |  |  |  |  |  |  |  |  |  |  |  |  |  |  |  |  |  |  |  |  |  |  |  |  |  |  |  |  |  |  |  |
|  | 1 | **1.4.2.2.1 TRACKING** |  |  | 2009-01-02 | 2015-04-01 |  |  |  |  |  |  |  |  |  |  |  |  |  |  |  |  |  |  |  |  |  |  |  |  |  |  |  |  |  |  |  |  |  |  |  |  |  |  |  |  |  |  |  |  |  |  |  |
|  | 1 | **1.4.2.2.1.1 SILICON DETECTOR** |  |  | 2009-10-01 | 2015-02-04 |  |  |  |  |  |  |  |  |  |  |  |  |  |  |  |  |  |  |  |  |  |  |  |  |  |  |  |  |  |  |  |  |  |  |  |  |  |  |  |  |  |  |  |  |  |  |  |
| 142211010E |  | SVT-FY10 Travel |  | 248d | 2009-10-01 A | 2010-09-30 A | 9-100M | 100% |  |  | TRAVEL | 4,395.14 |  | 100 | 100 | 0 | 4395.140713 | ELOUADRHIRI L | 1 | 1 | 07-024 | E | LATIFA E | 11-005 | 11-026 | 11 -035 | 12-013 |  |  |  |  |  |  |  |  |  |  |  |  |  |  |  |  |  |  |  |  |  |  |  |  |  |  |
| 142211005 |  | SVT-P-#1 Daq Production, Silicon Sensor Assys Labor FY10 |  | 20d | 2010-10-01 A | 2010-10-29 A | 12222000a, 9-100M FS+22d, 12222015M, 9-110M | 100% | 2010-10-01 | 2010-10-28 | ELEC TECH [568.23 h]; MECH DES [90.4 h]; SCIENTIST [126.56 h]; COMP SCIENT [180.8 h]; CONTRB UNIV LBR [2272.91 h]; PD UNIV STAFF [258.29 h]; ELEC DES [284.11 h]; VISTNG USERS [568.23 h]; MSHOP; MECH ENG [90.4 h]; MECH TECH [180.8 h]; ELEC ENG [154.97 h] | 119,512.24 | 111,821.25 |  |  | 0 | 116057.7192 | ELOUADRHIRI L | 1 | 1 |  | P | LATIFA E | 11-005 | 11-026 | 11 -035 | 12-013 | APP | 08-016 | 42211 | 09-012 | 11-001 |  |  |  |  |  |  |  |  |  |  |  |  |  |  |  |  |  |  |  |  |  |
| 142211011E |  | SVT-FY11 Travel |  | 248d | 2010-10-01 A | 2011-09-30 A | 142211010E | 100% |  |  | TRAVEL | 4,535.34 |  | 100 | 100 | 0 | 4535.34 | ELOUADRHIRI L | 1 | 1 | 07-024 | E | LATIFA E | 11-005 | 11-026 | 11 -035 | 12-013 |  |  |  |  |  | 8.46774193 | 91.53225806 |  |  |  |  |  |  |  |  |  |  |  |  |  |  |  |  |  |  |  |
| 142211004 |  | SVT Assembly Area & Clean Room |  | 32d | 2010-12-01 A | 2011-01-24 A | 9-100M FS+205d, 9-110M | 100% |  |  | PROCUREMENT<$50K 60 NO ESCALATION FY11; PROCUREMENT>$50K 69 NO ESCALATION FY11 | 120,000 |  |  |  | 0 | 120000 | ELOUADRHIRI L | 1 | 1 |  | D | LATIFA E | 11-005 | 11-026 | 11 -035 | 12-013 |  |  |  |  |  |  |  | 0 | 120000 | 12000000 | 100 | 10-060 |  |  |  |  |  |  |  |  |  |  |  |  |  |  |
| 142211005b |  | Vend Fab SVT Barrel Sensors Layers 1-3 Peg Point #1 NRE for Hybrid Mask |  | 28d | 2010-12-07 A | 2011-01-24 A | 12222000a, 12222015M, 9-110M FS+45d | 100% |  |  | PROCUREMENT<$50K 60 NO ESCALATION; PROCUREMENT>$50K 69 NO ESCALATION | 51,800 |  |  |  | 0 | 51800 | ELOUADRHIRI L | 1 | 1 |  | D | LATIFA E | 11-005 | 11-026 | 11 -035 | 12-013 | APP | 08-016 | 42211 | 09-012 | 11-001 |  |  | 0 | 51800 | 5180000 | 100 |  | 11-013 |  |  |  |  |  |  |  |  |  |  |  |  |  |
| 142211005c |  | Vend Fab SVT Barrel Sensors Layers 1-3 Peg Point #2 NRE for Intermediate Mask |  | 32d | 2010-12-07 A | 2011-01-28 A | 142211005b FS-33d | 100% |  |  | PROCUREMENT>$50K 69 NO ESCALATION | 51,800 |  |  |  | 0 | 51800 | ELOUADRHIRI L | 1 | 1 |  | D | LATIFA E | 11-005 | 11-026 | 11 -035 | 12-013 | APP | 08-016 | 42211 | 09-012 | 11-001 |  |  | 0 | 51800 | 5180000 | 100 |  | 11-013 |  |  |  |  |  |  |  |  |  |  |  |  |  |
| 142211005d |  | Vend Fab SVT Barrel Sensors Layers 1-3 Peg Point #3 NRE for FAR Mask |  | 32d | 2010-12-07 A | 2011-01-28 A | 142211005c FS-33d | 100% |  |  | PROCUREMENT>$50K 69 NO ESCALATION | 51,800 |  |  |  | 0 | 51800 | ELOUADRHIRI L | 1 | 1 |  | D | LATIFA E | 11-005 | 11-026 | 11 -035 | 12-013 | APP | 08-016 | 42211 | 09-012 | 11-001 |  |  | 0 | 51800 | 5180000 | 100 |  | 11-013 |  |  |  |  |  |  |  |  |  |  |  |  |  |
| 142211005f |  | Vend Fab SVT Barrel Sensors Layers 1-3 Peg Point #4 NRE for Mask Redesign |  | 182d | 2010-12-07 A | 2011-08-31 A | 142211005d FS-33d | 100% |  |  | PROCUREMENT>$50K 69 NO ESCALATION | 43,500 |  |  |  | 0 | 43500 | ELOUADRHIRI L | 1 | 1 |  | D | LATIFA E | 11-005 | 11-026 | 11 -035 | 12-013 | APP | 08-016 | 42211 | 09-012 | 11-001 |  |  | 0 | 43500 | 4350000 | 100 |  | 11-013 |  |  |  |  |  |  |  |  |  |  |  |  |  |
| 142211005g |  | Vend Fab SVT Barrel Sensors Layers 1-3 Peg Point #5 Hybrid Wafers Qty 3 |  | 180d | 2010-12-07 A | 2011-08-29 A | 142211005f FS-90d | 100% |  |  | PROCUREMENT>$50K 69 NO ESCALATION | 22,872 |  |  |  | 0 | 22872 | ELOUADRHIRI L | 1 | 1 |  | D | LATIFA E | 11-005 | 11-026 | 11 -035 | 12-013 | APP | 08-016 | 42211 | 09-012 | 11-001 |  |  | 0 | 22872 | 2287200 | 100 |  | 11-013 |  |  |  |  |  |  |  |  |  |  |  |  |  |
| 142211005h |  | Vend Fab SVT Barrel Sensors Layers 1-3 Peg Point #6 Intermediate Wafers Qty 3 |  | 180d | 2010-12-07 A | 2011-08-29 A | 142211005g FS-117d | 100% |  |  | PROCUREMENT>$50K 69 NO ESCALATION | 22,872 |  |  |  | 0 | 22872 | ELOUADRHIRI L | 1 | 1 |  | D | LATIFA E | 11-005 | 11-026 | 11 -035 | 12-013 | APP | 08-016 | 42211 | 09-012 | 11-001 |  |  | 0 | 22872 | 2287200 | 100 |  | 11-013 |  |  |  |  |  |  |  |  |  |  |  |  |  |
| 142211005j |  | Vend Fab SVT Barrel Sensors Layers 1-3 Peg Point #7 FAR Wafers Qty 3 |  | 180d | 2010-12-07 A | 2011-08-29 A | 142211005h FS-117d | 100% |  |  | PROCUREMENT>$50K 69 NO ESCALATION | 22,872 |  |  |  | 0 | 22872 | ELOUADRHIRI L | 1 | 1 |  | D | LATIFA E | 11-005 | 11-026 | 11 -035 | 12-013 | APP | 08-016 | 42211 | 09-012 | 11-001 |  |  | 0 | 22872 | 2287200 | 100 |  | 11-013 |  |  |  |  |  |  |  |  |  |  |  |  |  |
| 142211005k |  | Vend Fab SVT Barrel Sensors Layers 1-3 Peg Point #8 Hybrid Sensors Qty 120 |  | 441d | 2010-12-07 A | 2012-09-17 A | 142211005j FS-117d | 100% |  |  | PROCUREMENT>$50K 69 NO ESCALATION | 156,600 |  |  |  | 0 | 156600 | ELOUADRHIRI L | 1 | 1 |  | D | LATIFA E | 11-005 | 11-026 | 11 -035 | 12-013 | APP | 08-016 | 42211 | 09-012 | 11-001 |  |  | 0 | 156600 | 15660000 | 100 |  | 11-013 | MP |  |  |  |  |  |  |  |  |  |  |  |  |
| 142211005n |  | Vend Fab SVT Barrel Sensors Layers 1-3 Peg Point #9 Intermediate Sensors Qty 120 |  | 441d | 2010-12-07 A | 2012-09-17 A | 142211005k FS-281d | 100% |  |  | PROCUREMENT>$50K 69 NO ESCALATION | 156,600 |  |  |  | 0 | 156600 | ELOUADRHIRI L | 1 | 1 |  | D | LATIFA E | 11-005 | 11-026 | 11 -035 | 12-013 | APP | 08-016 | 42211 | 09-012 | 11-001 |  |  | 0 | 156600 | 15660000 | 100 |  | 11-013 | MP |  |  |  |  |  |  |  |  |  |  |  |  |
| 142211005p |  | Vend Fab SVT Barrel Sensors Layers 1-3 Peg Point #7 FAR Sensors Qty 120 |  | 441d | 2010-12-07 A | 2012-09-17 A | 142211005n FS-281d | 100% |  |  | PROCUREMENT>$50K 69 NO ESCALATION | 156,600 |  |  |  | 0 | 156600 | ELOUADRHIRI L | 1 | 1 |  | D | LATIFA E | 11-005 | 11-026 | 11 -035 | 12-013 | APP | 08-016 | 42211 | 09-012 | 11-001 |  |  | 0 | 156600 | 15660000 | 100 |  | 11-013 | MP |  |  |  |  |  |  |  |  |  |  |  |  |
| 142211005a |  | SVT-P-#1 Daq Production, Silicon Sensor Assys Labor FY11 |  | 9d | 2011-01-04 A | 2011-01-17 A | 142211005 | 100% | 2011-01-04 | 2011-01-14 | ELEC DES [155.89 h]; VISTNG USERS [311.77 h]; MSHOP; MECH ENG [49.6 h]; MECH TECH [99.2 h]; ELEC ENG [85.03 h]; ELEC TECH [311.77 h]; MECH DES [49.6 h]; SCIENTIST [69.44 h]; COMP SCIENT [99.2 h]; CONTRB UNIV LBR [1247.09 h]; PD UNIV STAFF [141.71 h] | 65,707.68 | 61,353.23 |  |  | 0 | 65707.6806 | ELOUADRHIRI L | 1 | 1 |  | P | LATIFA E | 11-005 | 11-026 | 11 -035 | 12-013 | APP | 08-016 | 42211 | 09-012 | 11-001 |  |  |  |  |  |  |  |  |  |  |  |  |  |  |  |  |  |  |  |  |  |
| 142211004a |  | Room Preperation and Finishes EEL230 |  | 19d | 2011-03-01 A | 2011-03-25 A | 9-110M FS+97d | 100% |  |  | PROCUREMENT<$50K 60 | 50,000 |  |  |  | 0 | 50000 | ELOUADRHIRI L | 1 | 1 |  | C | LATIFA E | 11-005 |  | 11 -035 |  |  |  |  |  |  |  |  | 0 | 50000 | 5000000 | 100 |  |  |  | 11-024 |  |  |  |  |  |  |  |  |  |  |  |
| 142211105 |  | SVT Clean Room Purchase |  | 65d | 2011-03-01 A | 2011-05-31 A | 9-110M FS+97d | 100% |  |  | PROCUREMENT<$50K 60; PROCUREMENT>$50K 69 | 302,000 |  |  |  | 0 | 302000 | ELOUADRHIRI L | 1 | 1 |  | D | LATIFA E | 11-005 |  | 11 -035 | 12-013 |  |  |  |  |  |  |  | 0 | 302000 | 30200000 | 100 |  |  |  | 11-024 |  |  |  |  |  |  |  |  |  |  |  |
| 142211105a |  | SVT Clean Room Electrical |  | 65d | 2011-03-01 A | 2011-05-31 A | 142211105 FS-107d | 100% |  |  | PROCUREMENT<$50K 60 | 60,000 |  |  |  | 0 | 60000 | ELOUADRHIRI L | 1 | 1 |  | D | LATIFA E | 11-005 |  | 11 -035 | 12-013 |  |  |  |  |  |  |  | 0 | 60000 | 6000000 | 100 |  |  |  | 11-024 |  |  |  |  |  |  |  |  |  |  |  |
| 142211105b |  | SVT Clean Room Data/Comm |  | 65d | 2011-03-01 A | 2011-05-31 A | 142211105a FS-107d | 100% |  |  | PROCUREMENT<$50K 60 | 10,000 |  |  |  | 0 | 10000 | ELOUADRHIRI L | 1 | 1 |  | D | LATIFA E | 11-005 |  | 11 -035 | 12-013 |  |  |  |  |  |  |  | 0 | 10000 | 1000000 | 100 |  |  |  | 11-024 |  |  |  |  |  |  |  |  |  |  |  |
| 142211105c |  | SVT Clean Room Demo/Interior Finishes |  | 65d | 2011-03-01 A | 2011-05-31 A | 142211105b FS-107d | 100% |  |  | PROCUREMENT<$50K 60 | 20,000 |  |  |  | 0 | 20000 | ELOUADRHIRI L | 1 | 1 |  | D | LATIFA E | 11-005 |  | 11 -035 | 12-013 |  |  |  |  |  |  |  | 0 | 20000 | 2000000 | 100 |  |  |  | 11-024 |  |  |  |  |  |  |  |  |  |  |  |
| 142211105d |  | SVT Clean Room Mechanicals |  | 65d | 2011-03-01 A | 2011-05-31 A | 142211105c FS-107d | 100% |  |  | PROCUREMENT<$50K 60 | 66,000 |  |  |  | 0 | 66000 | ELOUADRHIRI L | 1 | 1 |  | D | LATIFA E | 11-005 |  | 11 -035 | 12-013 |  |  |  |  |  |  |  | 0 | 66000 | 6600000 | 100 |  |  |  | 11-024 |  |  |  |  |  |  |  |  |  |  |  |
| 142211105f |  | SVT Clean Room Sprinklers |  | 65d | 2011-03-01 A | 2011-05-31 A | 142211105d FS-107d | 100% |  |  | PROCUREMENT<$50K 60 | 5,000 |  |  |  | 0 | 5000 | ELOUADRHIRI L | 1 | 1 |  | D | LATIFA E | 11-005 |  | 11 -035 | 12-013 |  |  |  |  |  |  |  | 0 | 5000 | 500000 | 100 |  |  |  | 11-024 |  |  |  |  |  |  |  |  |  |  |  |
| 142211105g |  | SVT Clean Room Moving Expenses |  | 65d | 2011-03-01 A | 2011-05-31 A | 142211105f FS-107d | 100% |  |  | PROCUREMENT<$50K 60 | 5,500 |  |  |  | 0 | 5500 | ELOUADRHIRI L | 1 | 1 |  | D | LATIFA E | 11-005 |  | 11 -035 | 12-013 |  |  |  |  |  |  |  | 0 | 5500 | 550000 | 100 |  |  |  | 11-024 |  |  |  |  |  |  |  |  |  |  |  |
| 142211105h |  | SVT Clean Room Furniture |  | 65d | 2011-03-01 A | 2011-05-31 A | 142211105g FS-107d | 100% |  |  | PROCUREMENT<$50K 60 | 30,000 |  |  |  | 0 | 30000 | ELOUADRHIRI L | 1 | 1 |  | D | LATIFA E | 11-005 |  | 11 -035 | 12-013 |  |  |  |  |  |  |  | 0 | 30000 | 3000000 | 100 |  |  |  | 11-024 |  |  |  |  |  |  |  |  |  |  |  |
| 142211210 |  | BST R1-R3 HBI - 6: Cable assemblies: HV, LV, and data (5) 1st article testing - Labor |  | 290.5d | 2011-03-16 A | 2012-05-14 A | 142211205 FS-100d | 100% |  |  | ELEC TECH [160 h] | 6,956.31 | 6,956.31 |  |  | 0 | 7060.8 | ELOUADRHIRI L | 1 | 1 |  | H | LATIFA E | 11-005 |  |  | 12-013 |  |  |  |  |  |  |  |  |  |  |  |  |  |  |  | Pat | HBI | 11-058 |  |  |  |  |  |  |  |  |
| 142211020 |  | SVT-Production R1, R2, R3 Stave Barrel & Wedge Assy (Frozen by CR11-005) |  | 105.31d | 2011-04-02 A | 2011-08-31 A | 142211005p FS-242d, 9-110M FS+63d, 142211005b FS-40d, 142211005a FS-40d, 142211005 | 100% | 2011-04-04 | 2011-08-31 | ELEC DES [117.32 h]; MECH DES [16 h]; COMP SCIENT [32 h]; CONTRB UNIV LBR [469.2 h]; PD UNIV STAFF [96 h]; ELEC ENG [64 h]; MECH TECH [64 h]; ELEC TECH [234.68 h]; SCIENTIST [26.67 h]; VISTNG USERS [234.66 h]; MECH ENG [16 h] | 38,229.24 | 38,229.24 |  |  | 0 | 38229.4966 | ELOUADRHIRI L | 1 | 1 |  | U | LATIFA E | 11-005 | 11-026 | 11 -035 | 12-013 | APP | 08-016 |  | 09-012 |  |  |  |  |  |  |  |  |  |  |  |  |  |  | C |  |  |  |  |  |  |  |
| 142211010a |  | Reverse Entry per CR11-005 |  | 21d | 2011-08-01 A | 2011-08-29 A | 9-110M | 100% |  |  | PD UNIV STAFF [-160 h]; MSHOP; MECH TECH [-112 h]; ELEC ENG [-96 h]; ELEC TECH [-352 h]; MECH ENG [-56 h]; MECH DES [-56 h]; ELEC DES [-176 h]; VISTNG USERS [-352 h]; COMP SCIENT [-112 h]; SCIENTIST [-24 h] | -70,227.68 | -65,547.2 |  |  |  |  | ELOUADRHIRI L | 1 | 1 |  | H | LATIFA E | 11-005 | 11-026 | 11 -035 | 12-013 | APP | 08-016 | 42211 | 09-012 |  |  |  |  |  |  |  |  | 11-013 |  |  |  |  |  | C |  |  |  |  |  |  |  |
| 142211020a |  | Reverse Entry per CR11-005 |  | 23d | 2011-08-01 A | 2011-08-31 A | 9-110M | 100% |  |  | COMP SCIENT [-32 h]; PD UNIV STAFF [-96 h]; MECH TECH [-64 h]; MECH ENG [-16 h]; ELEC ENG [-64 h]; ELEC TECH [-234.67 h]; MECH DES [-16 h]; SCIENTIST [-26.67 h]; VISTNG USERS [-234.67 h]; ELEC DES [-117.33 h] | -38,229.5 | -38,229.5 |  |  |  |  | ELOUADRHIRI L | 1 | 1 |  | H | LATIFA E | 11-005 | 11-026 | 11 -035 | 12-013 | APP | 08-016 |  | 09-012 |  |  |  |  |  |  |  |  |  |  |  |  |  |  | C |  |  |  |  |  |  |  |
| 142211109M |  | HBI - 2011 Replan - Milestone | milestone | 0d | 2011-08-01 A | 2011-08-01 A | 9-110M | 100% | 2011-09-01 | 2011-09-01 |  |  |  |  |  |  | 0 | ELOUADRHIRI L | 1 | 1 |  | M | LATIFA E | 11-005 |  |  | 12-013 |  |  |  |  |  |  |  |  |  |  |  |  |  |  |  | Pat | HBI | 11-058 |  | 12-054F |  |  |  |  |  |  |
| 142211110 |  | BST R1-R3 Collab-MSU - Contract award for full chain test, 1st article - Proc |  | 371d | 2011-08-01 A | 2013-02-11 A | 142211109M | 100% | 2011-08-01 | 2013-01-31 | PROCUREMENT>$50K 69 NO ESCALATION FY12; PROCUREMENT<$50K 60 NO ESCALATION FY12 | 97,940 |  |  |  | 0 | 97940 | ELOUADRHIRI L | 1 | 1 |  | H | LATIFA E | 11-005 |  |  | 12-013 |  |  |  |  |  |  |  | 0 | 97940 | 9794000 | 100 |  |  | MP |  | Pat |  |  |  |  | OPC A | XX |  |  |  |  |
| 142211120 |  | HBI - SVT Engineering and Construction Oversight FY11 |  | 44.85d | 2011-08-01 A | 2011-10-03 A | 142211109M | 100% |  |  | SCIENTIST [264 h] | 18,076.44 | 18,076.45 | 100 | 100 | 0 | 18065.52 | ELOUADRHIRI L | 1 | 1 |  | E | LATIFA E | 11-005 |  |  |  |  |  |  |  |  | 31.25 | 68.75 |  |  |  |  |  |  |  |  | Pat | HBI |  |  |  |  |  | 12-001 |  |  |  |
| 142211140 |  | BST R1-R3 HBI - 1 ASIC: ASIC production: testing, and dicing - Proc |  | 23d | 2011-08-01 A | 2011-08-31 A | 142211109M | 100% |  |  | PROCUREMENT<$50K 60 NO ESCALATION FY12; PROCUREMENT>$50K 69 NO ESCALATION FY12 | 81,164 |  |  |  | 0 | 81164 | ELOUADRHIRI L | 1 | 1 |  | D | LATIFA E | 11-005 |  |  | 12-013 |  |  |  |  |  |  |  | 0 | 81164 | 8116400 | 100 |  |  |  |  | Pat | HBI | 11-058 |  | 12-054F |  |  |  |  |  |  |
| 142211145 |  | BST R1-R3 HBI - 2 Sensors: Sensors received and inspected by JLab (1st article and production) - Labor FY11 |  | 59.76d | 2011-08-01 A | 2011-10-24 A | 142211005j, 142211005g, 142211005h | 100% |  |  | SCIENTIST [33.63 h]; ELEC ENG [67.26 h]; ELEC TECH [67.26 h] | 9,859.36 | 10,127.05 |  |  | 0 | 9777.2499 | ELOUADRHIRI L | 1 | 1 |  | U | LATIFA E | 11-005 |  |  | 12-013 |  |  |  |  |  |  |  |  |  |  |  |  |  |  |  | Pat | HBI | 11-058 |  |  |  |  | 12-001 | 12-027F |  |  |
| 142211145a |  | BST R1-R3 HBI - 2 Sensors: Sensors received and inspected by JLab (1st article and production) - Labor FY12 |  | 60d | 2011-08-01 A | 2011-10-24 A | 142211145 FS-275d | 100% |  |  | SCIENTIST [188.79 h]; ELEC ENG [377.58 h]; ELEC TECH [377.58 h] | 55,353.1 | 55,353.1 |  |  | 0 | 56635.1121 | ELOUADRHIRI L | 1 | 1 |  | U | LATIFA E | 11-005 |  |  | 12-013 |  |  |  |  |  |  |  |  |  |  |  |  |  |  |  | Pat | HBI | 11-058 |  |  |  |  | 12-001 | 12-027F | 12-053 |  |
| 142211145aa |  | BST R1-R3 HBI - 2 Sensors: Sensors received and inspected by JLab (1st article and production) - Labor FY13 |  | 60d | 2011-08-01 A | 2011-10-24 A | 142211145a | 100% |  |  | ELEC TECH [35.16 h]; SCIENTIST [17.58 h]; ELEC ENG [35.16 h] | 5,154.44 | 5,154.44 |  |  | 0 | 5442.0648 | ELOUADRHIRI L | 1 | 1 |  | U | LATIFA E | 11-005 |  |  | 12-013 |  |  |  |  |  |  |  |  |  |  |  |  |  |  |  | Pat | HBI | 11-058 |  |  |  |  | 12-001 | 12-027F | 12-053 |  |
| 142211155 |  | BST FNAL - Contract Preparations |  | 11d | 2011-08-01 A | 2011-08-15 A | 142211109M | 100% |  |  | SCIENTIST [160 h]; ELEC ENG [160 h] | 21,889.6 | 21,889.6 |  |  | 0 | 21889.6 | ELOUADRHIRI L | 1 | 1 |  | H | LATIFA E | 11-005 |  |  | 12-013 |  |  |  |  |  |  |  |  |  |  |  |  |  |  |  | Pat |  | 11-058 |  |  |  |  |  | 12-027F |  |  |
| 142211190 |  | BST R1-R3 HBI - 5 Electronics: HFCB validation tests (1st article) - Proc |  | 175d | 2011-08-01 A | 2012-04-16 A | 142211109M | 100% |  |  | PROCUREMENT<$50K 60 NO ESCALATION FY12 | 18,543 |  |  |  | 0 | 18543 | ELOUADRHIRI L | 1 | 1 |  | D | LATIFA E | 11-005 |  |  | 12-013 |  |  |  |  |  |  |  | 0 | 18543 | 1854300 | 100 |  |  |  |  | Pat | HBI | 11-058 |  | 12-054F |  |  |  |  |  |  |
| 142211195 |  | BST R1-R3 HBI - 6: Cable assemblies: HV, LV, and data (1) specifications and procurement prep - Labor FY11 |  | 23d | 2011-08-01 A | 2011-08-31 A | 142211109M | 100% |  |  | ELEC ENG [29.83 h]; MECH TECH [29.83 h] | 3,324.56 | 3,324.56 |  |  | 0 | 3324.5535 | ELOUADRHIRI L | 1 | 1 |  | D | LATIFA E | 11-005 |  |  |  |  |  |  |  |  |  |  |  |  |  |  |  |  |  |  | Pat | HBI | 11-058 |  |  |  |  | 12-001 |  |  |  |
| 142211195a |  | BST R1-R3 HBI - 6: Cable assemblies: HV, LV, and data (1) specifications and procurement prep - Labor FY12 |  | 23d | 2011-08-01 A | 2011-08-31 A | 142211195 | 100% |  |  | MECH TECH [10.17 h]; ELEC ENG [10.17 h] | 1,133.44 | 1,133.44 |  |  | 0 | 1169.55 | ELOUADRHIRI L | 1 | 1 |  | D | LATIFA E | 11-005 |  |  |  |  |  |  |  |  |  |  |  |  |  |  |  |  |  |  | Pat | HBI | 11-058 |  |  |  |  | 12-001 |  |  |  |
| 142211200 |  | BST R1-R3 HBI - 6: Cable assemblies: HV, LV, and data (3) assemble components for fabrication - Labor |  | 21d | 2011-08-01 A | 2011-08-29 A | 142211195a | 100% |  |  | ELEC TECH [160 h] | 6,843.2 | 6,843.2 |  |  | 0 | 7060.8 | ELOUADRHIRI L | 1 | 1 |  | D | LATIFA E | 11-005 |  |  |  |  |  |  |  |  |  |  |  |  |  |  |  |  |  |  | Pat | HBI | 11-058 |  |  |  |  |  |  |  |  |
| 142211215 |  | BST R1-R3 HBI - 7 Sloco: HV, LV, PS (1) module components and crates specs and procurement prep - Labor FY11 |  | 111d | 2011-08-01 A | 2012-01-16 A | 142211109M | 100% | 2011-08-01 | 2012-01-13 | MECH TECH [13.75 h]; ELEC ENG [13.75 h] | 1,561.9 | 1,561.9 |  |  | 0 | 1532.4375 | ELOUADRHIRI L | 1 | 1 |  | H | LATIFA E | 11-005 |  |  | 12-013 |  |  |  |  |  |  |  |  |  |  |  |  |  |  |  | Pat | HBI | 11-058 |  | 12-054F |  |  | 12-001 |  |  |  |
| 142211215a |  | BST R1-R3 HBI - 7 Sloco: HV, LV, PS (1) module components and crates specs and procurement prep - Labor FY12 |  | 111d | 2011-08-01 A | 2012-01-16 A | 142211215 FS-90d | 100% | 2011-08-01 | 2012-01-13 | MECH TECH [26.25 h]; ELEC ENG [26.25 h] | 2,981.81 | 2,981.81 |  |  | 0 | 3018.75 | ELOUADRHIRI L | 1 | 1 |  | H | LATIFA E | 11-005 |  |  | 12-013 |  |  |  |  |  |  |  |  |  |  |  |  |  |  |  | Pat | HBI | 11-058 |  | 12-054F |  |  | 12-001 |  |  |  |
| 142211235 |  | BST R1-R3 HBI - 8 DAq: VME: (1) specification and procurement preparation - Labor |  | 59d | 2011-08-01 A | 2011-10-24 A | 142211109M | 100% | 2011-08-01 | 2011-10-21 | MECH TECH [40 h]; ELEC ENG [40 h] | 4,494.1 | 4,494.1 |  |  | 0 | 4458 | ELOUADRHIRI L | 1 | 1 |  | H | LATIFA E | 11-005 |  |  | 12-013 |  |  |  |  |  |  |  |  |  |  |  |  |  |  |  | Pat | HBI | 11-058 |  | 12-054F |  |  |  |  |  |  |
| 142211280 |  | BST R1-R3 MECH GRP - Modules: 1st article backing structure manufacturing drawing - Labor |  | 21d | 2011-08-01 A | 2011-08-29 A | 142211109M | 100% |  |  | MECH ENG [320 h]; MECH DES [320 h]; ELEC ENG [160 h] | 47,622.4 | 47,622.4 |  |  | 0 | 47622.4 | ELOUADRHIRI L | 1 | 1 |  | H | LATIFA E | 11-005 |  |  | 12-013 |  |  |  |  |  |  |  |  |  |  |  |  |  |  |  | Pat | MECH | 11-058 |  | 12-054F |  |  |  | 12-027F |  |  |
| 142211285 |  | BST R1-R3 MECH GRP - Modules: 1st article cold plate manufacturing drawing - Labor FY11 |  | 111d | 2011-08-01 A | 2012-01-16 A | 142211109M | 100% | 2011-08-01 | 2012-01-13 | MECH ENG [125.71 h]; MECH DES [125.71 h]; ELEC ENG [83.81 h] | 20,529.06 | 20,529.06 |  |  | 0 | 20141.0651 | ELOUADRHIRI L | 1 | 1 |  | H | LATIFA E | 11-005 |  |  | 12-013 |  |  |  |  |  |  |  |  |  |  |  |  |  |  |  | Pat | MECH | 11-058 |  | 12-054F |  |  | 12-001 |  |  |  |
| 142211285a |  | BST R1-R3 MECH GRP - Modules: 1st article cold plate manufacturing drawing - Labor FY12 |  | 111d | 2011-08-01 A | 2012-01-16 A | 142211285 FS-41d | 100% | 2011-08-01 | 2012-01-13 | MECH ENG [114.29 h]; MECH DES [114.29 h]; ELEC ENG [76.19 h] | 18,663.68 | 18,663.68 |  |  | 0 | 18895.3305 | ELOUADRHIRI L | 1 | 1 |  | H | LATIFA E | 11-005 |  |  | 12-013 |  |  |  |  |  |  |  |  |  |  |  |  |  |  |  | Pat | MECH | 11-058 |  | 12-054F |  |  | 12-001 |  |  |  |
| 142211305 |  | BST R1-R3 MECH GRP - Support structure for cold plate 1st article tests: Manufacturing Drawings - Labor |  | 111d | 2011-08-01 A | 2012-01-16 A | 142211109M | 100% | 2011-08-01 | 2012-01-13 | MECH ENG [80 h]; MECH DES [80 h] | 9,347.14 | 9,347.14 |  |  | 0 | 9170.4 | ELOUADRHIRI L | 1 | 1 |  | H | LATIFA E | 11-005 |  |  | 12-013 |  |  |  |  |  |  |  |  |  |  |  |  |  |  |  | Pat | MECH | 11-058 |  | 12-054F |  |  |  |  |  |  |
| 142211010 |  | SVT-P-#2 Daq Production, Silicon Sensor Assys (Frozen by CR11-005) |  | 11d | 2011-08-15 A | 2011-08-29 A | 9-120M, 142211005b, 142211005a, 142211004, 142211005p FS-202d, 142211005 | 100% |  |  | COMP SCIENT [112 h]; ELEC DES [176 h]; VISTNG USERS [352 h]; MSHOP; CONTRB UNIV LBR [1408 h]; PD UNIV STAFF [160 h]; MECH ENG [56 h]; MECH DES [56 h]; MECH TECH [112 h]; ELEC ENG [96 h]; ELEC TECH [352 h]; SCIENTIST [24 h] | 70,227.2 | 65,547.2 |  |  | 0 | 70227.68 | ELOUADRHIRI L | 1 | 1 |  | D | LATIFA E | 11-005 | 11-026 | 11 -035 | 12-013 | APP | 08-016 | 42211 | 09-012 |  |  |  |  |  |  |  |  | 11-013 |  |  |  |  |  | C |  |  |  |  |  |  |  |
| 142211115 |  | HBI - Hardware infrastructure: configuring and installing- Labor FY11 |  | 49.08d | 2011-08-15 A | 2011-10-24 A | 142211109M FS+10d | 100% |  |  | ELEC TECH [34.39 h] | 1,485.23 | 1,485.23 |  |  | 0 | 1470.8603 | ELOUADRHIRI L | 1 | 1 |  | H | LATIFA E | 11-005 |  |  |  |  |  |  |  |  |  |  |  |  |  |  |  |  |  |  | Pat | HBI |  |  |  |  |  | 12-001 |  |  |  |
| 142211115a |  | HBI - Hardware infrastructure: configuring and installing- Labor FY12 |  | 50d | 2011-08-15 A | 2011-10-24 A | 142211115 FS-85d | 100% |  |  | ELEC TECH [125.61 h] | 5,427.01 | 5,427.01 |  |  | 0 | 5543.1693 | ELOUADRHIRI L | 1 | 1 |  | H | LATIFA E | 11-005 |  |  |  |  |  |  |  |  |  |  |  |  |  |  |  |  |  |  | Pat | HBI |  |  |  |  |  | 12-001 |  |  |  |
| 142211185 |  | BST R1-R3 HBI - 5 Electronics: Pitch Adapter - Proc (Full set for 1st article, R1-R3, R4) |  | 361d | 2011-08-15 A | 2013-04-15 A | 142211109M | 100% | 2011-08-15 | 2013-01-31 | PROCUREMENT<$50K 60 NO ESCALATION FY12 | 21,683 |  |  |  | 0 | 21683 | ELOUADRHIRI L | 1 | 1 |  | D | LATIFA E | 11-005 |  |  | 12-013 |  |  |  |  |  |  |  | 0 | 21683 | 2168300 | 100 |  |  |  |  | Pat | HBI | 11-058 |  |  |  | XX |  |  |  |  |
| 142211205 |  | BST R1-R3 HBI - 6: Cable assemblies: HV, LV, and data (4) 1st article - Proc |  | 121d | 2011-08-15 A | 2012-02-13 A | 142211200 FS-61d | 100% |  |  | PROCUREMENT<$50K 60 | 21,759.68 |  |  |  | 0 | 21759.68 | ELOUADRHIRI L | 1 | 1 |  | D | LATIFA E | 11-005 |  |  |  |  |  |  |  |  |  |  | 0 | 21759.68 | 2175968 | 100 |  |  |  |  | Pat | HBI | 11-058 |  |  |  |  |  |  |  |  |
| 142211505 |  | BST R4 HBI - 2 Sensors: Sensors for R4 - Proc |  | 272d | 2011-08-15 A | 2012-09-17 A | 142211500M FS-170d, 142211005p FS-240d | 100% |  |  | PROCUREMENT>$50K 69; PROCUREMENT<$50K 60 | 354,200.93 |  |  |  | 0 | 354200.93 | ELOUADRHIRI L | 1 | 1 |  | D | LATIFA E | 11-005 |  |  |  |  |  |  |  |  |  |  | 0 | 354200.93 | 35420093 | 100 |  |  |  |  | Pat | HBI | 11-058 |  |  | OPC A |  |  |  |  |  |
| 142211500M |  | Start of BST R4 Production | milestone | 0d | 2011-08-15 A | 2011-08-15 A | 142211005p FS-170d | 100% | 2012-11-27 | 2012-11-27 |  |  |  |  |  |  | 0 | ELOUADRHIRI L | 1 | 1 |  | M | LATIFA E | 11-005 |  |  |  |  |  |  |  |  |  |  |  |  |  |  |  |  |  |  | Pat | MECH | 11-058 |  |  |  |  |  |  |  |  |
| 142211165 |  | BST R1-R3 HBI - 3: Modules: DAq development front end electronics (1st article) - Labor FY11 |  | 175d | 2011-08-29 A | 2012-05-14 A | 142211109M | 100% |  |  | SCIENTIST [170.87 h]; ELEC ENG [170.87 h] | 24,019.55 | 24,019.55 |  |  | 0 | 23376.7247 | ELOUADRHIRI L | 1 | 1 |  | S | LATIFA E | 11-005 |  |  | 12-013 |  |  |  |  |  |  |  |  |  |  |  |  |  |  |  | Pat | HBI | 11-058 |  |  |  |  | 12-001 |  |  | ST |
| 142211165a |  | BST R1-R3 HBI - 3: Modules: DAq development front end electronics (1st article) - Labor FY12 |  | 175d | 2011-08-29 A | 2012-05-14 A | 142211165 FS-165d | 100% |  |  | ELEC ENG [629.13 h]; SCIENTIST [629.13 h] | 88,438.1 | 88,438.1 |  |  | 0 | 88814.2821 | ELOUADRHIRI L | 1 | 1 |  | S | LATIFA E | 11-005 |  |  | 12-013 |  |  |  |  |  |  |  |  |  |  |  |  |  |  |  | Pat | HBI | 11-058 |  |  |  |  | 12-001 |  |  | ST |
| 142211170 |  | BST R1-R3 HBI - 4: DAq: 1st article software - Labor FY11 |  | 217.53d | 2011-08-29 A | 2012-07-16 A | 142211109M | 100% |  |  | SCIENTIST [129.41 h]; ELEC ENG [129.41 h] | 18,206.55 | 18,206.55 |  |  | 0 | 17704.5821 | ELOUADRHIRI L | 1 | 1 |  | S | LATIFA E | 11-005 |  |  | 12-013 |  |  |  |  |  |  |  |  |  |  |  |  |  |  |  | Pat | HBI | 11-058 |  |  |  |  | 12-001 |  |  | ST |
| 142211170a |  | BST R1-R3 HBI - 4: DAq: 1st article software - Labor FY12 |  | 218d | 2011-08-29 A | 2012-07-16 A | 142211170 FS-165d | 100% |  |  | SCIENTIST [470.59 h]; ELEC ENG [470.59 h] | 66,207.31 | 66,207.31 |  |  | 0 | 66433.1903 | ELOUADRHIRI L | 1 | 1 |  | S | LATIFA E | 11-005 |  |  | 12-013 |  |  |  |  |  |  |  |  |  |  |  |  |  |  |  | Pat | HBI | 11-058 |  |  |  |  | 12-001 |  |  | ST |
| 142211160 |  | FNAL/Jlab/MSU Testing of 1st article sensors |  | 79d | 2011-09-01 A | 2011-12-30 A | 142211158M, 142211155 FS-20d | 100% |  |  | PROCUREMENT<$50K 60 NO ESCALATION | 5,495 |  |  |  | 0 | 5495 | ELOUADRHIRI L | 1 | 1 |  | D | LATIFA E | 11-005 |  |  | 12-013 |  |  |  |  |  |  |  | 0 | 5495 | 549500 | 100 |  |  |  |  | Pat |  | 11-058 |  |  |  |  |  | 12-027F |  |  |
| 142211160a |  | FNAL Module Design Review |  | 37d | 2011-09-01 A | 2011-10-24 A | 142211160 FS-79d | 100% |  |  | PROCUREMENT<$50K 60 NO ESCALATION | 5,495 |  |  |  | 0 | 5495 | ELOUADRHIRI L | 1 | 1 |  | D | LATIFA E | 11-005 |  |  | 12-013 |  |  |  |  |  |  |  | 0 | 5495 | 549500 | 100 |  |  |  |  | Pat |  | 11-058 |  |  |  |  |  | 12-027F |  |  |
| 142211160b |  | FNAL Module Design Report & Recommendations |  | 88d | 2011-09-01 A | 2012-01-16 A | 142211160a FS-42d | 100% | 2011-09-01 | 2012-01-13 | PROCUREMENT<$50K 60 NO ESCALATION | 5,495 |  |  |  | 0 | 5495 | ELOUADRHIRI L | 1 | 1 |  | D | LATIFA E | 11-005 |  |  | 12-013 |  |  |  |  |  |  |  | 0 | 5495 | 549500 | 100 |  |  |  |  | Pat |  | 11-058 |  |  |  |  |  | 12-027F |  |  |
| 142211160c |  | FNAL/Jlab Develop Module Construction, Assembly, & QA/QC procedures |  | 108d | 2011-09-01 A | 2012-02-13 A | 142211160b FS-42d | 100% |  |  | PROCUREMENT<$50K 60 NO ESCALATION | 8,702 |  |  |  | 0 | 8702 | ELOUADRHIRI L | 1 | 1 |  | D | LATIFA E | 11-005 |  |  | 12-013 |  |  |  |  |  |  |  | 0 | 8702 | 870200 | 100 |  |  |  |  | Pat |  | 11-058 |  |  |  |  |  | 12-027F |  |  |
| 142211160d |  | FNAL Construction & Testing (FNAL/Jlab) of 1st article electrical grade modules |  | 88d | 2011-09-01 A | 2012-01-16 A | 142211150 FS-20d, 142211160c FS-62d | 100% | 2011-09-01 | 2012-01-13 | PROCUREMENT<$50K 60 NO ESCALATION; PROCUREMENT>$50K 69 NO ESCALATION | 72,002 |  |  |  | 0 | 72002 | ELOUADRHIRI L | 1 | 1 |  | D | LATIFA E | 11-005 |  |  | 12-013 |  |  |  |  |  |  |  | 0 | 72002 | 7200200 | 100 |  |  |  |  | Pat |  | 11-058 |  |  |  |  |  | 12-027F |  |  |
| 142211160f |  | FNAL Design of Assembly Fixtures (6.5 months) |  | 279d | 2011-09-01 A | 2012-10-15 A | 142211160d FS-62d | 100% |  |  | PROCUREMENT>$50K 69 NO ESCALATION | 37,130 |  |  |  | 0 | 37130 | ELOUADRHIRI L | 1 | 1 |  | D | LATIFA E | 11-005 |  |  | 12-013 |  |  |  |  |  |  |  | 0 | 37130 | 3713000 | 100 |  |  | MP |  | Pat |  | 11-058 |  |  |  |  |  | 12-027 |  |  |
| 142211160g |  | FNAL Receive & test (Jlab/FNAL) R1-R3 Production Sensors (4 batches) Part A |  | 240d | 2011-09-01 A | 2012-08-20 A | 142211005k FS-170d, 142211160f FS-268d | 100% |  |  | PROCUREMENT>$50K 69 NO ESCALATION | 61,681 |  |  |  | 0 | 61681 | ELOUADRHIRI L | 1 | 1 |  | D | LATIFA E | 11-005 |  |  | 12-013 |  |  |  |  |  |  |  | 0 | 61681 | 6168100 | 100 |  |  | MP |  | Pat |  | 11-058 |  |  | OPC A |  |  | 12-027 |  |  |
| 142211150 |  | BST R1-R3 HBI - 2 Sensors: Sensors shipped to FNAL (1st article) |  | 10d | 2011-09-12 A | 2011-09-26 A | 142211145a FS-310d, 142211145aa FS-310d, 142211005j | 100% | 2011-09-12 | 2011-09-23 | MECH TECH [80 h] | 3,445.6 | 3,445.6 |  |  | 0 | 3445.6 | ELOUADRHIRI L | 1 | 1 |  | H | LATIFA E | 11-005 |  |  | 12-013 |  |  |  |  |  |  |  |  |  |  |  |  |  |  |  | Pat | HBI | 11-058 |  |  |  |  |  | 12-027F |  |  |
| 142211245 |  | BST R1-R3 HBI - 8 DAq: VME: (3) 1st article testing - Labor |  | 15d | 2011-10-03 A | 2011-10-24 A | 142211240 | 100% | 2011-10-03 | 2011-10-21 | ELEC TECH [160 h]; SCIENTIST [160 h]; ELEC ENG [160 h] | 29,648 | 29,648 |  |  | 0 | 29648 | ELOUADRHIRI L | 1 | 1 |  | H | LATIFA E | 11-005 |  |  | 12-013 |  |  |  |  |  |  |  |  |  |  |  |  |  |  |  | Pat | HBI | 11-058 |  | 12-054F |  |  |  |  |  |  |

Notes:
- 142211110: Explanation: Phase / Procurement / Labor / Total $ / 1 / 125,000 / 2 / 75,000 / 3 / 100,000 / protective enclosure for F1 F2 F3 F4 / 12,500 / protective enclosure for R1 R2 R3 R4 / 12,500 / Phase 1 / Activity ID / Procurement / Labor / Total $ / Phase 2 / Activity ID / Procurement / Labor / Total $ / Phase 3 / Activity ID / Procurement / Labor / Total $
- 142211140: Explanation: dicing (Mosis) $40,880, testing / (TestEdge) $36,300, testing/Jlab (chuck adapter $360, probe card / adapter $2170, estimate for adapter board $1454) $3984 / Steps: Wafers; testing; JLab testing
- 142211190: Explanation: hybrid assembly boards(10) $13,300, connectors $4540 / Vendor (MSU/FNAL) will die mount / added time and $ for population $2,871
- 142211205: Explanation: cable (1000') $2821.55, cable (1000') $795.73, connector molex (300 @ / 0.09472) $28.42, cable (2000') $11,300, connectors (40 @ 0.789) / $31.56, straight plug conncetor 37 pin (20 @ 124.13) $2482.60, / straight plug conncetor 51 pin (20 @ 181.36) / $3627.20
- 142211505: Explanation: 216 sensors @ $1540; feeds into 2500L FY13 (R1 R2 R3); anticipate / receiving sensor in 3 months (Feb 13)
- 142211165: Steps: Establish communication with a single chip via registers (done); Read back data from single chip over a single line (done); Read back data from single chip over 2, 4, 6 output lines (done); Read back data from half module (2 chips) over all output lines (done); Read back data from full module (4 chips) over all output lines. (done)
- 142211165a: Steps: Establish communication with a single chip via registers (done); Read back data from single chip over a single line (done); Read back data from single chip over 2, 4, 6 output lines (done); Read back data from half module (2 chips) over all output lines (done); Read back data from full module (4 chips) over all output lines. (done)
- 142211170: Steps: SCM HDL/FPGA firmware developmen (done); SCM prototype/testing driver (done); SCM CODA driver (done); SCM System Integration (done)
- 142211170a: Steps: SCM HDL/FPGA firmware developmen (done); SCM prototype/testing driver (done); SCM CODA driver (done); SCM System Integration (done)

| ID | Activity | Type | Duration | Start | Finish | Predecessors | Complete | Planned start | Planned finish | Resources | Cost | Actual cost | Calculated Remaining Total Cost | MONTHLY EV COST | RESP - Responsibility | STRT%COMP for CM EVM | FNSH%COMP for CM EVM | EVMS Reporting Codes | CAM RESPONSIBLE | Pat's Code | CR 11-005 | SVT | CR 11-058 | CR 12-001 | CR 12-013 | CR 12-054 | LOE % Pre Calc | LOE % | LOE Divider | LOE Multiplier | CR 07-024 | CR 11-026 | CR 11-035 | CR 12-027 | Remaining Material Cost Based on % Compl | Claimed Material Cost Based on % Complet | Initial Claimed Material Calc | Claimed Material Divider | MARCH!!! | OPC Allison | Phil Dev | CR 12-053 | CR 12-055 | Activities with Steps | New H Claim |
| --- | --- | --- | --- | --- | --- | --- | --- | --- | --- | --- | --- | --- | --- | --- | --- | --- | --- | --- | --- | --- | --- | --- | --- | --- | --- | --- | --- | --- | --- | --- | --- | --- | --- | --- | --- | --- | --- | --- | --- | --- | --- | --- | --- | --- | --- |
| 142211260 | BST R1-R3 HBI - 9 DAq-SCM (1) components and PCBs: specification and procurement prep - Labor |  | 56d | 2011-10-03 A | 2011-12-26 A | 142211109M, 9-120M | 100% | 2011-10-03 | 2011-12-21 | MECH TECH [40 h]; ELEC ENG [40 h] | 4,600 | 4,600 | 0 | 4600 | ELOUADRHIRI L | 1 | 1 | H | LATIFA E | Pat | 11-005 | HBI |  |  |  |  |  |  |  |  |  |  |  |  |  |  |  |  |  |  |  |  |  |  |  |
| 142211310 | BST R1-R3 MECH GRP - Support structure for cold plate 1st article tests: procurement prep - Labor FY11 |  | 67d | 2011-10-03 A | 2012-01-16 A | 142211305 FS-20d | 100% | 2011-10-03 | 2012-01-13 | MECH ENG [26.67 h] | 1,870.1 | 1,870.1 | 0 | 1812.2265 | ELOUADRHIRI L | 1 | 1 | H | LATIFA E | Pat | 11-005 | MECH | 11-058 | 12-001 | 12-013 | 12-054F |  |  |  |  |  |  |  |  |  |  |  |  |  |  |  |  |  |  |  |
| 142211310a | BST R1-R3 MECH GRP - Support structure for cold plate 1st article tests: procurement prep - Labor FY12 |  | 67d | 2011-10-03 A | 2012-01-16 A | 142211310 FS-60d | 100% | 2011-10-03 | 2012-01-13 | MECH ENG [13.33 h] | 934.7 | 934.7 | 0 | 934.6996 | ELOUADRHIRI L | 1 | 1 | H | LATIFA E | Pat | 11-005 | MECH | 11-058 | 12-001 | 12-013 | 12-054F |  |  |  |  |  |  |  |  |  |  |  |  |  |  |  |  |  |  |  |
| 142211012E | SVT-FY12 Travel |  | 247d | 2011-10-03 A | 2012-09-28 A | 142211011E, 142211004a | 100% |  |  | TRAVEL | 4,680.02 |  | 0 | 4680.02 | ELOUADRHIRI L | 1 | 1 | E | LATIFA E |  | 11-005 |  |  |  | 12-013 |  | 7.69230769 | 92.3076923 | 100 | 100 | 07-024 | 11-026 | 11 -035 |  |  |  |  |  |  |  |  |  |  |  |  |
| 142211125 | HBI - SVT Engineering and Construction Oversight FY12 |  | 247d | 2011-10-03 A | 2012-09-28 A | 142211120 | 100% |  |  | SCIENTIST [1470 h] | 103,796.7 | 103,796.7 | 0 | 103796.7 | ELOUADRHIRI L | 1 | 1 | E | LATIFA E | Pat | 11-005 | HBI |  | 12-001 |  |  | 7.69230769 | 92.3076923 | 100 | 100 |  |  |  |  |  |  |  |  |  |  |  |  |  |  |  |
| 142211158M | BST FNAL - 1st article & production SOW Agreement signed (milestone) | milestone | 0d | 2011-10-03 A | 2011-10-03 A | 9-110M FS+227d | 100% | 2011-11-01 | 2011-11-01 |  |  |  |  | 0 | ELOUADRHIRI L | 1 | 1 | M | LATIFA E | Pat | 11-005 |  | 11-058 |  | 12-013 |  |  |  |  |  |  |  |  | 12-027F |  |  |  |  |  |  |  |  |  |  |  |
| 142211240 | BST R1-R3 HBI - 8 DAq: VME: (2) crates and cards - Proc |  | 328d | 2011-10-17 A | 2013-01-28 A | 142211235 | 100% | 2011-10-17 | 2013-02-15 | PROCUREMENT<$50K 60 | 26,182 |  | 0 | 26182 | ELOUADRHIRI L | 1 | 1 | D | LATIFA E | Pat | 11-005 | HBI | 11-058 |  | 12-013 | 12-054F |  |  |  |  |  |  |  |  | 0 | 26182 | 2618200 | 100 | XX |  |  |  |  |  |  |
| 142211160h | FNAL Receive & test (Jlab/FNAL) R1-R3 Production Sensors (4 batches) Part B |  | 198d | 2011-11-01 A | 2012-08-20 A | 142211160g FS-240d, 142211005k FS-170d | 100% |  |  | PROCUREMENT<$50K 60 NO ESCALATION | 2,601 |  | 0 | 2601 | ELOUADRHIRI L | 1 | 1 | D | LATIFA E | Pat | 11-005 |  | 11-058 |  | 12-013 |  |  |  |  |  |  |  |  | 12-027 | 0 | 2601 | 260100 | 100 |  | OPC A |  |  |  |  |  |
| 142211160j | FNAL QA/QC and Assembly of Fixtures |  | 306d | 2011-11-01 A | 2013-01-28 A | 142211160h FS-229d, 142211255a FS-170d, 142211255 FS-170d | 100% | 2011-11-01 | 2013-01-31 | PROCUREMENT<$50K 60 NO ESCALATION | 42,294 |  | 0 | 42294 | ELOUADRHIRI L | 1 | 1 | D | LATIFA E | Pat | 11-005 |  | 11-058 |  | 12-013 |  |  |  |  |  |  |  |  | 12-027F | 0 | 42294 | 4229400 | 100 | XX | OPC A | MP |  |  |  |  |
| 142211160k | FNAL Construction of 1st article (mechanical grade) modules |  | 306d | 2011-11-01 A | 2013-02-11 A | 142211160j FS-269d | 100% | 2011-11-01 | 2013-01-31 | PROCUREMENT<$50K 60 NO ESCALATION; PROCUREMENT>$50K 69 NO ESCALATION | 91,472 |  | 0 | 91472 | ELOUADRHIRI L | 1 | 1 | D | LATIFA E | Pat | 11-005 |  | 11-058 |  | 12-013 |  |  |  |  |  |  |  |  |  | 0 | 91472 | 9147200 | 100 | XX | OPC A | MP |  |  |  |  |
| 142211160n | FNAL design and construct module shipping containers |  | 257d | 2011-11-01 A | 2012-11-12 A | 142211160k FS-270d | 100% |  |  | PROCUREMENT>$50K 69 NO ESCALATION | 21,100 |  | 0 | 21100 | ELOUADRHIRI L | 1 | 1 | D | LATIFA E | Pat | 11-005 |  | 11-058 |  | 12-013 |  |  |  |  |  |  |  |  |  | 0 | 21100 | 2110000 | 100 |  | OPC A | MP |  |  |  |  |
| 142211160p | FNAL/Jlab/MSU Testing of 1st article (mechanical grade) modules |  | 306d | 2011-11-01 A | 2013-02-11 A | 142211160n FS-270d, 142211165 FS-145d, 142211180 FS-185d, 142211165a FS-145d | 100% | 2011-11-01 | 2013-01-31 | PROCUREMENT>$50K 69 NO ESCALATION | 11,528 |  | 0 | 11528 | ELOUADRHIRI L | 1 | 1 | D | LATIFA E | Pat | 11-005 |  | 11-058 |  | 12-013 |  |  |  |  |  |  |  |  |  | 0 | 11528 | 1152800 | 100 | XX | OPC A |  |  |  |  |  |
| 142211160q | FNAL/Jlab review of module testing |  | 306d | 2011-11-01 A | 2013-04-15 A | 142211160p FS-270d | 100% | 2011-11-01 | 2013-01-31 | PROCUREMENT>$50K 69 NO ESCALATION | 22,248 |  | 0 | 22248 | ELOUADRHIRI L | 1 | 1 | D | LATIFA E | Pat | 11-005 |  | 11-058 |  | 12-013 |  |  |  |  |  |  |  |  |  | 0 | 22248 | 2224800 | 100 | XX | OPC A | MP |  |  |  |  |
| 142211160r | FNAL/Jlab revise module construction & assembly & QA/QC procedures |  | 306d | 2011-11-01 A | 2013-04-15 A | 142211160q FS-270d | 100% | 2011-11-01 | 2013-01-31 | PROCUREMENT>$50K 69 NO ESCALATION | 5,764 |  | 0 | 5764 | ELOUADRHIRI L | 1 | 1 | D | LATIFA E | Pat | 11-005 |  | 11-058 |  | 12-013 |  |  |  |  |  |  |  |  |  | 0 | 5764 | 576400 | 100 | XX | OPC A |  |  |  |  |  |
| 142211160s | FNAL QA/QC and assembly of production fixtures |  | 306d | 2011-11-01 A | 2013-02-22 A | 142211160r FS-270d | 100% | 2011-11-01 | 2013-01-31 | PROCUREMENT>$50K 69 NO ESCALATION | 38,853 |  | 0 | 38853 | ELOUADRHIRI L | 1 | 1 | D | LATIFA E | Pat | 11-005 |  | 11-058 |  | 12-013 |  |  |  |  |  |  |  |  |  | 0 | 38853 | 3885300 | 100 | XX | OPC A | MP |  |  |  |  |
| 142211160t | FNAL Construction and test (Jlab/FNAL) of R1-R3 production modules (60 modules) Part A |  | 474d | 2011-11-01 A | 2013-08-30 A | 142211185 FS-70d, 142211160s FS-365d, 142211360 FS-250d | 100% | 2011-11-01 | 2013-09-30 | PROCUREMENT>$50K 69 NO ESCALATION | 983.02 |  | 22828 | 983.02 | ELOUADRHIRI L | 1 | 1 | D | LATIFA E | Pat | 11-005 |  | 11-058 |  | 12-013 |  |  |  |  |  |  |  |  |  | 0 | 983.02 | 98302 | 100 |  | OPC A | MP |  |  |  |  |
| 142211325 | BST R1-R3 MECH GRP - Modules:for assy 1st article BST, mounting, and alignment fixture -mfg dwgs |  | 66d | 2011-11-01 A | 2012-02-13 A | 142211285a FS-40d, 142211280 FS-162d | 100% |  |  | MECH ENG [80 h]; MECH DES [80 h] | 9,463.2 | 9,463.2 | 0 | 9463.2 | ELOUADRHIRI L | 1 | 1 | H | LATIFA E | Pat | 11-005 | MECH | 11-058 |  | 12-013 | 12-054F |  |  |  |  |  |  |  | 12-027F |  |  |  |  |  |  |  |  |  |  |  |
| 142211265 | BST R1-R3 HBI - 9 DAq-SCM (2) system for 1st article - Proc |  | 44d | 2011-12-03 A | 2012-02-13 A | 142211260 FS-58d | 100% | 2011-12-05 | 2012-02-13 | PROCUREMENT<$50K 60 | 30,957 |  | 0 | 30957 | ELOUADRHIRI L | 1 | 1 | D | LATIFA E | Pat | 11-005 | HBI |  |  |  |  |  |  |  |  |  |  |  |  | 0 | 30957 | 3095700 | 100 |  |  |  |  |  |  |  |
| 142211405 | BST R1-R3 MECH GRP - Protective enclosure system (1) Manufacturing Drawings - Labor |  | 325d | 2011-12-03 A | 2013-08-30 A | 142211109M FS+96d | 100% | 2011-12-05 | 2013-04-01 | ELEC TECH [40 h]; MECH TECH [40 h] | 3,584.95 | 3,602.55 | 1771.4 | 3542.8 | ELOUADRHIRI L | 1 | 1 | H | LATIFA E | Pat | 11-005 | MECH |  |  |  | 12-054F |  |  |  |  |  |  |  | 12-027F |  |  |  |  |  | OPC A |  |  |  |  |  |
| 142211450 | BST R1-R3 MECH GRP - Cooling system: preparation, manufacturing drawings - Labor |  | 284d | 2011-12-03 A | 2013-07-15 A | 142211109M FS+100d | 100% | 2011-12-05 | 2013-01-31 | MECH TECH [40 h]; MECH DES [80 h]; ELEC ENG [80 h]; MECH ENG [120 h] | 19,867.52 | 19,996.9 | 9845.2 | 19690.4 | ELOUADRHIRI L | 1 | 1 | H | LATIFA E | Pat | 11-005 | MECH | 11-058 |  | 12-013 | 12-054F |  |  |  |  |  |  |  |  |  |  |  |  | XX | OPC A |  |  |  |  |  |
| 142211290 | BST R1-R3 MECH GRP - Cold plate 1st article model: procurement prep - Labor |  | 5d | 2012-01-16 A | 2012-01-23 A | 142211285a FS-20d | 100% | 2012-01-17 | 2012-01-23 | MECH ENG [40 h] | 2,804.8 | 2,804.8 | 0 | 2804.8 | ELOUADRHIRI L | 1 | 1 | H | LATIFA E | Pat | 11-005 | MECH | 11-058 |  | 12-013 | 12-054F |  |  |  |  |  |  |  |  |  |  |  |  |  |  |  |  |  |  |  |
| 142211315 | BST R1-R3 MECH GRP - Support structure to hold 1st article tests for cold plate: (1) procurement - Proc |  | 5d | 2012-01-16 A | 2012-01-23 A | 142211310a, 142211310 | 100% | 2012-01-17 | 2012-01-23 | PROCUREMENT<$50K 60 | 5,159.5 |  | 0 | 5159.5 | ELOUADRHIRI L | 1 | 1 | D | LATIFA E | Pat | 11-005 | MECH | 11-058 |  | 12-013 | 12-054F |  |  |  |  |  |  |  |  | 0 | 5159.5 | 515950 | 100 |  |  |  |  |  |  |  |
| 142211320 | BST R1-R3 MECH GRP - Support structure to hold 1st art. tests for cold plate (2) constr/assem (for burn-in tests) - Lab |  | 5d | 2012-01-16 A | 2012-01-23 A | 142211315 | 100% | 2012-01-17 | 2012-01-23 | MECH ENG [40 h]; MECH TECH [80 h] | 6,360 | 6,360 | 0 | 6360 | ELOUADRHIRI L | 1 | 1 | H | LATIFA E | Pat | 11-005 | MECH | 11-058 |  | 12-013 | 12-054F |  |  |  |  |  |  |  |  |  |  |  |  |  |  |  |  |  |  |  |
| 142211330 | BST R1-R3 MECH GRP - Modules:for assy 1st article BST, mounting, and alignment fixture - proc prep - Labor |  | 127d | 2012-01-16 A | 2012-07-16 A | 142211325 FS-20d, 9-120M | 100% | 2012-01-17 | 2012-07-16 | MECH ENG [40 h] | 2,804.8 | 2,804.8 | 0 | 2804.8 | ELOUADRHIRI L | 1 | 1 | H | LATIFA E | Pat | 11-005 | MECH | 11-058 |  | 12-013 | 12-054F |  |  |  |  |  |  |  | 12-027F |  |  |  |  |  |  |  |  |  |  |  |
| 142211175 | BST R1-R3 HBI - 4: DAq: readout card 1st article - Proc |  | 6d | 2012-02-06 A | 2012-02-13 A | 142211170a | 100% |  |  | PROCUREMENT<$50K 60 | 30,957 |  | 0 | 30957 | ELOUADRHIRI L | 1 | 1 | D | LATIFA E | Pat | 11-005 | HBI | 11-058 |  | 12-013 |  |  |  |  |  |  |  |  |  | 0 | 30957 | 3095700 | 100 |  |  |  |  |  |  |  |
| 142211270 | BST R1-R3 HBI - 9 DAq-SCM (3) 1st article testing - Labor |  | 138d | 2012-03-03 A | 2012-09-17 A | 142211265, 9-120M FS+121d | 100% | 2012-03-05 | 2012-09-17 | ELEC ENG [80 h]; ELEC TECH [160 h] | 12,705.6 | 12,705.6 | 0 | 12705.6 | ELOUADRHIRI L | 1 | 1 | H | LATIFA E | Pat | 11-005 | HBI |  |  | 12-013 |  |  |  |  |  |  |  |  |  |  |  |  |  |  |  |  |  |  |  |  |
| 142211385 | BST R1-R3 HBI - 7 Sloco: Slow controls and charge calibration system: (1) specification and procurement prep - Labor |  | 21d | 2012-03-19 A | 2012-04-16 A | 142211190 FS-15d, 142211160 | 100% |  |  | MECH TECH [40 h]; ELEC ENG [40 h] | 4,600 | 4,600 | 0 | 4600 | ELOUADRHIRI L | 1 | 1 | H | LATIFA E | Pat | 11-005 | HBI | 11-058 |  |  |  |  |  |  |  |  |  |  | 12-027F |  |  |  |  |  |  |  |  |  |  |  |
| 142211295 | BST R1-R3 MECH GRP - Cold plate 1st article tests: (1) procurement - Proc |  | 11d | 2012-04-02 A | 2012-04-16 A | 9-120M FS+124d, 142211290 | 100% |  |  | PROCUREMENT<$50K 60 | 8,255.2 |  | 0 | 8255.2 | ELOUADRHIRI L | 1 | 1 | D | LATIFA E | Pat | 11-005 | MECH | 11-058 |  | 12-013 | 12-054F |  |  |  |  |  |  |  |  | 0 | 8255.2 | 825520 | 100 |  |  |  |  |  |  |  |
| 142211300 | BST R1-R3 MECH GRP - Cold plate 1st article tests: (2) construct and assemble - Labor |  | 6d | 2012-04-09 A | 2012-04-16 A | 142211295 | 100% |  |  | MECH TECH [80 h]; MECH ENG [40 h] | 6,360 | 6,360 | 0 | 6360 | ELOUADRHIRI L | 1 | 1 | H | LATIFA E | Pat | 11-005 | MECH | 11-058 |  | 12-013 | 12-054F |  |  |  |  |  |  |  |  |  |  |  |  |  |  |  |  |  |  |  |
| 142211370 | BST R1-R3 HBI - 6: Cable assemblies: HV, LV, and data fabrication and testing - Labor |  | 178d | 2012-04-16 A | 2013-08-30 A | 142211365a FS-250d, 142211365 FS-120d | 100% | 2012-04-16 | 2013-01-03 | ELEC TECH [400 h] | 17,845.28 | 18,024.73 | 9108 | 18216 | ELOUADRHIRI L | 1 | 1 | H | LATIFA E | Pat | 11-005 | HBI |  |  | 12-013 |  |  |  |  |  |  |  |  |  |  |  |  |  |  | OPC A |  |  |  |  |  |
| 142211400 | BST R1-R3 HBI - 7Sloco:Slow controls for monitor and charge calib system: (4) develop sloco software (1/2) - Labor FY12 |  | 127.6d | 2012-04-16 A | 2012-10-15 A | 142211395 FS-250d | 100% |  |  | SCIENTIST [25.6 h]; ELEC ENG [12.8 h] | 2,717.96 | 2,717.96 | 0 | 2710.784 | ELOUADRHIRI L | 1 | 1 | H | LATIFA E | Pat | 11-005 | HBI | 11-058 |  |  | 12-054F |  |  |  |  |  |  |  | 12-027 |  |  |  |  |  | OPC A |  | 12-053 |  |  |  |
| 142211400a | BST R1-R3 HBI - 7Sloco:Slow controls for monitor and charge calib system: (4) develop sloco software (1/2) - Labor FY13 |  | 208d | 2012-04-16 A | 2013-08-30 A | 142211400 FS-145d | 100% | 2012-04-16 | 2013-02-15 | SCIENTIST [134.4 h]; ELEC ENG [67.2 h] | 14,430.06 | 14,531.39 | 7342.608 | 14685.216 | ELOUADRHIRI L | 1 | 1 | H | LATIFA E | Pat | 11-005 | HBI | 11-058 |  |  | 12-054F |  |  |  |  |  |  |  | 12-027 |  |  |  |  | XX |  |  | 12-053 |  |  |  |
| 142211410 | BST R1-R3 MECH GRP - Protective enclosure system (1) specifications and procurement prep - Labor |  | 270d | 2012-04-16 A | 2013-08-30 A | 142211405 FS-150d | 100% | 2012-04-16 | 2013-05-15 | MECH TECH [40 h]; ELEC TECH [40 h] | 3,606.95 | 3,617.61 | 1771.4 | 3542.8 | ELOUADRHIRI L | 1 | 1 | H | LATIFA E | Pat | 11-005 | MECH |  |  |  | 12-054F |  |  |  |  |  |  |  | 12-027F |  |  |  |  |  | OPC A |  |  |  |  |  |
| 142211430 | BST R1-R3 HBI - 7 Sloco-Slow controls charge calibration system: develop slow controls (2/2) - Labor |  | 108d | 2012-04-16 A | 2012-09-17 A | 142211385 | 100% |  |  | SCIENTIST [160 h]; ELEC ENG [80 h] | 16,942.4 | 16,942.4 | 0 | 16942.4 | ELOUADRHIRI L | 1 | 1 | H | LATIFA E | Pat | 11-005 | HBI | 11-058 |  |  |  |  |  |  |  |  |  |  |  |  |  |  |  |  |  |  |  |  |  |  |
| 142211455 | BST R1-R3 MECH GRP - Cooling system: preparation, procurement prep- Labor |  | 208d | 2012-04-16 A | 2013-08-30 A | 142211450 FS-130d | 100% | 2012-04-16 | 2013-02-15 | MECH ENG [40 h] | 2,844 | 2,864.01 | 1402.4 | 2804.8 | ELOUADRHIRI L | 1 | 1 | H | LATIFA E | Pat | 11-005 | MECH | 11-058 |  | 12-013 | 12-054F |  |  |  |  |  |  |  |  |  |  |  |  |  | OPC A |  |  |  |  |  |
| 142211535 | BST R4 HBI - 6: Cable assemblies: HV, LV, and data (2) R4 - Labor |  | 277d | 2012-04-16 A | 2013-08-30 A | 142211530 FS-210d | 100% | 2012-04-16 | 2013-05-24 | ELEC TECH [160 h] | 7,191.11 | 7,209.89 | 3643.2 | 7286.4 | ELOUADRHIRI L | 1 | 1 | H | LATIFA E | Pat | 11-005 | HBI |  |  |  |  |  |  |  |  |  |  |  |  |  |  |  |  |  | OPC A |  |  |  |  |  |
| 142211220 | BST R1-R3 HBI - 7 Sloco: HV, LV, PS (2) modules 1st article - Proc |  | 10d | 2012-05-01 A | 2012-05-14 A | 9-120M FS+147d, 142211215a | 100% |  |  | PROCUREMENT<$50K 60 | 29,469 |  | 0 | 29469 | ELOUADRHIRI L | 1 | 1 | D | LATIFA E | Pat | 11-005 | HBI | 11-058 |  | 12-013 | 12-054F |  |  |  |  |  |  |  |  | 0 | 29469 | 2946900 | 100 |  |  |  |  |  |  |  |
| 142211225 | BST R1-R3 HBI - 7 Sloco: HV, LV, PS (3) modules components: 1st article testing - Labor |  | 78d | 2012-05-01 A | 2012-08-20 A | 142211220 | 100% |  |  | ELEC TECH [160 h]; ELEC ENG [40 h] | 9,883.2 | 9,883.2 | 0 | 9883.2 | ELOUADRHIRI L | 1 | 1 | H | LATIFA E | Pat | 11-005 | HBI | 11-058 |  | 12-013 | 12-054F |  |  |  |  |  |  |  |  |  |  |  |  |  |  |  |  |  |  |  |
| 142211255 | BST JLab - Tooling Production Part A |  | 186d | 2012-05-01 A | 2012-12-17 A | 9-120M FS+163d, 142211160f FS-85d | 100% | 2012-05-01 | 2013-01-31 | PROCUREMENT<$50K 60 | 5,000 |  | 0 | 5000 | ELOUADRHIRI L | 1 | 1 | D | LATIFA E | Pat | 11-005 |  | 11-058 |  | 12-013 |  |  |  |  |  |  |  |  |  | 0 | 5000 | 500000 | 100 |  |  |  |  | 12-055 |  |  |
| 142211275 | BST R1-R3 HBI - 9 DAq-SCM (4) develop program and test (1/2) - Labor FY12 |  | 186d | 2012-05-01 A | 2013-01-25 A | 142211270 FS-40d | 100% | 2012-05-01 | 2013-01-31 | SCIENTIST [298.22 h]; ELEC ENG [298.22 h] | 42,676.91 | 42,660.11 | 0 | 42099.7174 | ELOUADRHIRI L | 1 | 1 | S | LATIFA E | Pat | 11-005 | HBI |  |  | 12-013 |  |  |  |  |  |  |  |  |  |  |  |  |  | XX | OPC A |  | 12-053 |  | ST |  |
| 142211275a | BST R1-R3 HBI - 9 DAq-SCM (4) develop program and test (1/2) - Labor FY13 |  | 186d | 2012-05-01 A | 2013-01-25 A | 142211275 FS-65d | 100% | 2012-05-01 | 2013-01-31 | SCIENTIST [101.78 h]; ELEC ENG [101.78 h] | 14,565.27 | 14,559.54 | 0 | 14826.2926 | ELOUADRHIRI L | 1 | 1 | S | LATIFA E | Pat | 11-005 | HBI |  |  | 12-013 |  |  |  |  |  |  |  |  |  |  |  |  |  | XX |  |  | 12-053 |  | ST |  |
| 142211365 | BST R1-R3 HBI - 6: Cable assemblies: HV, LV, and data (6) R1 R2 R3 - Proc Part A |  | 116d | 2012-05-01 A | 2012-10-13 A | 142211210 | 100% | 2012-05-01 | 2012-10-12 | PROCUREMENT<$50K 60 NO ESCALATION FY13 | 10,000 |  | 0 | 10000 | ELOUADRHIRI L | 1 | 1 | D | LATIFA E | Pat | 11-005 | HBI |  |  | 12-013 |  |  |  |  |  |  |  |  |  | 0 | 10000 | 1000000 | 100 |  | OPC A |  |  | 12-055 |  |  |
| 142211530 | BST R4 HBI - 6: Cable assemblies: HV, LV, and data (1) R4 - Proc |  | 186d | 2012-05-01 A | 2013-08-30 A | 9-130M FS-90d | 100% | 2012-05-01 | 2013-01-31 | PROCUREMENT<$50K 60 | 19,581.99 |  | 3916.398 | 19581.99 | ELOUADRHIRI L | 1 | 1 | D | LATIFA E | Pat | 11-005 | HBI |  |  |  |  |  |  |  |  |  |  |  |  | 0 | 19581.99 | 1958199 | 100 | XX | OPC A |  |  |  |  |  |
| 142211355M | Start of R1-R3 Production | milestone | 0d | 2012-07-02 A | 2012-07-02 A | 142211350M FS-250d | 100% | 2013-03-21 | 2013-03-21 |  |  |  |  | 0 | ELOUADRHIRI L | 1 | 1 | M | LATIFA E | Pat | 11-005 | MECH | 11-058 |  | 12-013 | 12-054F |  |  |  |  |  |  |  |  |  |  |  |  |  | OPC A |  |  |  |  |  |
| 142211375 | BST R1-R3 HBI - 7 Sloco: HV, LV, PS (1) modules R1 R2 R3 - Proc |  | 144d | 2012-07-02 A | 2013-02-11 A | 142211109M, 142211230 FS-120d | 100% | 2012-07-02 | 2013-01-31 | PROCUREMENT<$50K 60 NO ESCALATION FY13; PROCUREMENT>$50K 69 NO ESCALATION FY13 | 88,407 |  | 0 | 88407 | ELOUADRHIRI L | 1 | 1 | D | LATIFA E | Pat | 11-005 | HBI |  |  | 12-013 |  |  |  |  |  |  |  |  |  | 0 | 88407 | 8840700 | 100 | XX | OPC A |  |  |  |  |  |
| 142211510 | BST R4 HBI - 5 Electronics: HFCB production modules R4 - Proc |  | 179d | 2012-07-02 A | 2013-08-30 A | 142211360 FS-275d | 100% | 2012-07-02 | 2013-03-22 | PROCUREMENT<$50K 60 | 39,470.66 |  | 35918.3006 | 39470.66 | ELOUADRHIRI L | 1 | 1 | D | LATIFA E | Pat | 11-005 | HBI | 11-058 |  | 12-013 | 12-054F |  |  |  |  |  |  |  |  | 0 | 39470.66 | 3947066 | 100 |  | OPC A |  |  |  |  |  |
| 142211360 | BST R1-R3 HBI - Electronics 5: HFCB modules R1 R2 R3 - Proc |  | 141d | 2012-07-20 A | 2013-08-30 A | 142211355M, 142211140, 142211190 | 100% | 2012-07-20 | 2013-02-15 | PROCUREMENT<$50K 60 NO ESCALATION FY13; PROCUREMENT>$50K 69 NO ESCALATION FY13 | 124,266.56 |  | 113082.5696 | 124266.56 | ELOUADRHIRI L | 1 | 1 | D | LATIFA E | Pat | 11-005 | HBI | 11-058 |  | 12-013 | 12-054F |  |  |  |  |  |  |  |  | 0 | 124266.56 | 12426656 | 100 |  | OPC A |  |  |  |  |  |
| 142211515 | BST R4 HBI - 5 Electronics: HFCB production modules assembly R4 - Proc |  | 157d | 2012-08-01 A | 2013-08-30 A | 142211510 FS-250d | 100% | 2012-08-01 | 2013-03-22 | PROCUREMENT<$50K 60 | 3,057.09 |  | 2781.9519 | 3057.09 | ELOUADRHIRI L | 1 | 1 | D | LATIFA E | Pat | 11-005 | HBI | 11-058 |  | 12-013 | 12-054F |  |  |  |  |  |  |  |  | 0 | 3057.09 | 305709 | 100 |  | OPC A |  |  |  |  |  |
| 142211550 | BST R4 HBI - 9 DAq- SCM custom crate system components R4 - Proc |  | 133d | 2012-08-01 A | 2013-02-11 A | 9-130M FS-20d | 100% | 2012-08-01 | 2013-02-15 | PROCUREMENT<$50K 60 | 38,333.43 |  | 0 | 38333.43 | ELOUADRHIRI L | 1 | 1 | D | LATIFA E | Pat | 11-005 | HBI |  |  |  |  |  |  |  |  |  |  |  |  | 0 | 38333.43 | 3833343 | 100 | XX | OPC A |  |  |  |  |  |
| 142211180 | BST R1-R3 HBI - 4: DAq: readout card ALTERNATE |  | 5d | 2012-09-03 A | 2012-09-10 A | 9-120M FS+225d, 142211175 | 100% | 2012-09-04 | 2012-09-10 | PROCUREMENT<$50K 60 | 18,574.2 |  | 0 | 18574.2 | ELOUADRHIRI L | 1 | 1 | D | LATIFA E | Pat | 11-005 | HBI | 11-058 |  | 12-013 |  |  |  |  |  |  |  |  |  | 0 | 18574.2 | 1857420 | 100 |  |  |  |  |  |  |  |
| 142211160v | FNAL Receive & test (Jlab/FNAL) R4 Production Sensors (3 batches) |  | 26d | 2012-09-10 A | 2012-10-15 A | 142211505 | 100% |  |  | PROCUREMENT>$50K 69 | 1,105.28 |  | 0 | 1105.28 | ELOUADRHIRI L | 1 | 1 | D | LATIFA E | Pat | 11-005 |  | 11-058 |  | 12-013 |  |  |  |  |  |  |  |  |  | 0 | 1105.28 | 110528 | 100 |  | OPC A |  |  |  |  |  |
| 142211230 | BST R1-R3 HBI - 7 Sloco: HV, LV, PS (4) crates - Proc (1st Articles and Production) |  | 106d | 2012-09-10 A | 2013-05-13 A | 142211220 FS+60d | 100% | 2012-09-10 | 2013-02-15 | PROCUREMENT<$50K 60 | 35,660.4 |  | 0 | 35660.4 | ELOUADRHIRI L | 1 | 1 | D | LATIFA E | Pat | 11-005 | HBI | 11-058 |  | 12-013 | 12-054F |  |  |  |  |  |  |  |  | 0 | 35660.4 | 3566040 | 100 | XX |  |  |  |  |  |  |
| 142211540 | BST R4 HBI - 7 Sloco: HV, LV, PS (1) modules R4 - Proc |  | 95d | 2012-09-10 A | 2013-07-15 A | 9-130M | 100% | 2012-09-10 | 2013-01-31 | PROCUREMENT>$50K 69; PROCUREMENT<$50K 60 | 60,818.12 |  | 27368.154 | 60818.12 | ELOUADRHIRI L | 1 | 1 | D | LATIFA E | Pat | 11-005 | HBI |  |  |  |  |  |  |  |  |  |  |  |  | 0 | 60818.12 | 6081812 | 100 | XX | OPC A |  |  |  |  |  |
| 142211013E | SVT-FY13 Travel |  | 228d | 2012-10-01 A | 2013-08-30 A | 142211012E | 100% |  |  | TRAVEL | 4,439.85 |  | 818.085114 | 4439.85 | ELOUADRHIRI L | 1 | 1 | E | LATIFA E |  | 11-005 |  |  |  | 12-013 |  | 8.06451612 | 91.93548387 | 100 | 100 | 07-024 | 11-026 | 11 -035 |  |  |  |  |  |  | OPC A |  |  |  |  |  |
| 142211130 | HBI - SVT Engineering and Construction Oversight FY13 |  | 248d | 2012-10-01 A | 2013-08-30 A | 142211125 | 100% | 2012-10-01 | 2013-09-30 | SCIENTIST [1241.12 h] | 90,428 | 90,428 | 16662.3534 | 90428.7318 | ELOUADRHIRI L | 1 | 1 | E | LATIFA E | Pat | 11-005 | HBI |  | 12-001 |  |  | 8.06451612 | 91.93548387 | 100 | 100 |  |  |  |  |  |  |  |  |  | OPC A |  |  |  |  |  |
| 142211365a | BST R1-R3 HBI - 6: Cable assemblies: HV, LV, and data (6) R1 R2 R3 - Proc Part B |  | 121d | 2012-10-01 A | 2013-04-15 A | 9-130M, 142211210 | 100% | 2012-10-01 | 2013-04-01 | PROCUREMENT<$50K 60 NO ESCALATION FY13 | 27,374.39 |  | 0 | 27374.39 | ELOUADRHIRI L | 1 | 1 | D | LATIFA E | Pat | 11-005 | HBI |  |  | 12-013 |  |  |  |  |  |  |  |  |  | 0 | 27374.39 | 2737439 | 100 |  | OPC A |  |  | 12-055 |  |  |
| 142211390 | BST R1-R3 HBI - 7 Sloco: Slow controls for monitoring and charge calibration system: (2) component procurement - Proc |  | 80d | 2012-10-01 A | 2013-08-30 A | 142211385 FS+60d, 9-120M FS+250d | 100% | 2012-10-01 | 2013-01-31 | PROCUREMENT<$50K 60 NO ESCALATION FY13 | 32,576.05 |  | 32576.05 | 32576.05 | ELOUADRHIRI L | 1 | 1 | D | LATIFA E | Pat | 11-005 | HBI | 11-058 |  |  | 12-054 |  |  |  |  |  |  |  | 12-027 | 0 | 32576.05 | 3257605 | 100 | XX | OPC A |  |  |  |  |  |
| 142211875 | Installation MECH GRP - Transport box BST: (1) manufacturing drawings - Labor |  | 6d | 2012-11-03 A | 2012-11-12 A | 9-130M | 100% | 2012-11-05 | 2012-11-12 | MECH DES [80 h]; MECH ENG [80 h] | 9,765.6 | 9,765.6 | 0 | 9765.6 | ELOUADRHIRI L | 1 | 1 | H | LATIFA E | Pat | 11-005 | MECH |  |  |  |  |  |  |  |  |  |  |  |  |  |  |  |  |  | OPC A |  |  |  |  |  |
| 142211840 | Installation MECH GRP - Installation cart: (1) MFG Drawings - Labor |  | 95d | 2012-11-05 A | 2013-08-30 A | 9-130M | 100% | 2012-11-05 | 2013-03-29 | MECH ENG [80 h]; MECH DES [240 h] | 17,719.2 | 17,719.2 | 8859.6 | 17719.2 | ELOUADRHIRI L | 1 | 1 | H | LATIFA E | Pat | 11-005 | MECH |  |  |  |  |  |  |  |  |  |  |  |  |  |  |  |  |  | OPC A |  |  |  |  |  |
| 142211880 | Installation MECH GRP - Transport box BST: (2) procurement prep - Labor |  | 6d | 2012-11-12 A | 2012-11-19 A | 142211875 FS-31d | 100% |  |  | MECH ENG [40 h] | 2,894.4 | 2,894.4 | 0 | 2894.4 | ELOUADRHIRI L | 1 | 1 | H | LATIFA E | Pat | 11-005 | MECH |  |  |  |  |  |  |  |  |  |  |  |  |  |  |  |  |  | OPC A |  |  |  |  |  |
| 142211885 | Installation MECH GRP - Transport box BST: (3) construct and assemble - Proc |  | 6d | 2012-11-12 A | 2012-11-19 A | 142211880 | 100% |  |  |  |  |  |  | 0 | ELOUADRHIRI L | 1 | 1 | Z | LATIFA E | Pat | 11-005 | MECH |  |  |  |  |  |  |  |  |  |  |  |  |  |  |  |  |  | OPC A |  |  |  |  |  |
| 142211890 | Installation MECH GRP - Transport box BST: (4) construct and assemble - Labor |  | 35d | 2012-11-12 A | 2013-01-18 A | 142211885 | 100% | 2012-11-12 | 2013-01-09 | MECH DES [80 h]; MECH ENG [80 h] | 9,765.6 | 9,765.6 | 0 | 9765.6 | ELOUADRHIRI L | 1 | 1 | H | LATIFA E | Pat | 11-005 | MECH |  |  |  |  |  |  |  |  |  |  |  |  |  |  |  |  | XX | OPC A |  |  |  |  |  |
| 142211255a | BST JLab - Tooling Production Part B |  | 41d | 2012-12-03 A | 2012-12-17 A | 9-120M FS+163d, 142211160f FS-85d | 100% | 2013-01-02 | 2013-03-01 | PROCUREMENT<$50K 60 | 20,797.5 |  | 0 | 20797.5 | ELOUADRHIRI L | 1 | 1 | D | LATIFA E | Pat | 11-005 |  | 11-058 |  | 12-013 |  |  |  |  |  |  |  |  |  | 0 | 20797.5 | 2079750 | 100 |  |  |  |  | 12-055 |  |  |
| 142211435 | BST R1-R3 HBI - 9 DAq-SCM (1) custom crate system components R1 R2 R3 - Proc |  | 54d | 2013-01-02 A | 2013-02-11 A | 142211275a FS-40d | 100% | 2013-01-02 | 2013-03-20 | PROCUREMENT<$50K 60; PROCUREMENT>$50K 69 | 102,222.49 |  | 0 | 102222.49 | ELOUADRHIRI L | 1 | 1 | D | LATIFA E | Pat | 11-005 | HBI | 11-058 |  | 12-013 |  |  |  |  |  |  |  |  |  | 0 | 102222.49 | 10222249 | 100 |  | OPC A |  |  |  |  |  |
| 142211465 | BST R1-R3 MECH GRP - Support, cooling, and alignment (1) of stave: manufacturing Drawings - Labor |  | 60d | 2013-01-02 A | 2013-08-30 A | 142211350 FS-175d | 100% | 2013-08-16 | 2013-11-08 | MECH ENG [160 h]; MECH DES [320 h]; MECH TECH [80 h] | 31,634.61 | 31,153.6 | 15576.8 | 31153.6 | ELOUADRHIRI L | 1 | 1 | H | LATIFA E | Pat | 11-005 | MECH | 11-058 |  | 12-013 | 12-054 |  |  |  |  |  |  |  |  |  |  |  |  |  | OPC A |  |  |  |  | Aug 12 |
| 142211395 | BST R1-R3 HBI - 7Sloco:Slow controls for monitoring and charge calib system: (3) assemble, test, and debug - Labor FY12 |  | 100d | 2013-01-15 A | 2013-08-30 A | 142211390 FS-115d | 100% | 2013-03-29 | 2013-08-19 | ELEC ENG [80 h]; ELEC TECH [480 h] | 27,684 | 27,684 | 13842 | 27684 | ELOUADRHIRI L | 1 | 1 | H | LATIFA E | Pat | 11-005 | HBI | 11-058 |  |  | 12-054 |  |  |  |  |  |  |  | 12-027 |  |  |  |  |  | OPC A |  | 12-053 |  |  |  |
| 142211470 | BST R1-R3 MECH GRP - Support, cooling, and alignment (2) of stave: procurement prep - Labor |  | 21d | 2013-01-31 A | 2013-08-30 A | 142211465 FS-90d | 100% | 2013-05-15 | 2013-06-13 | MECH ENG [40 h] | 2,894.4 | 2,894.4 | 1447.2 | 2894.4 | ELOUADRHIRI L | 1 | 1 | H | LATIFA E | Pat | 11-005 | MECH | 11-058 |  | 12-013 | 12-054 |  |  |  |  |  |  |  |  |  |  |  |  |  | OPC A |  |  |  |  |  |
| 142211440 | BST R1-R3 HBI - 9 DAq-SCM (2) custom crate fabrication and test - Labor |  | 54d | 2013-02-06 A | 2013-02-22 A | 142211435 FS-30d | 100% | 2013-04-04 | 2013-06-19 | ELEC ENG [80 h]; ELEC TECH [320 h] | 20,397.6 | 20,397.6 | 0 | 20397.6 | ELOUADRHIRI L | 1 | 1 | H | LATIFA E | Pat | 11-005 | HBI | 11-058 |  | 12-013 |  |  |  |  |  |  |  |  |  |  |  |  |  |  | OPC A |  |  |  |  |  |
| 142211520 | BST R4 HBI - 5 Electronics: HFCB assemble electronics for modules - Labor |  | 228d | 2013-02-11 A | 2013-08-30 A | 142211515 FS-300d | 100% | 2013-04-01 | 2014-03-03 | MECH TECH [40 h] | 1,860.01 | 1,834.4 | 917.2 | 1834.4 | ELOUADRHIRI L | 1 | 1 | H | LATIFA E | Pat | 11-005 | HBI | 11-058 |  | 12-013 | 12-054F |  |  |  |  |  |  |  |  |  |  |  |  |  | OPC A |  |  |  |  |  |
| 142211380 | BST R1-R3 HBI - 7 Sloco: HV, LV, PS (3) distribution system (fabricate) - Labor |  | 116d | 2013-04-01 A | 2013-08-30 A | 142211375 FS+19d | 100% | 2013-05-01 | 2013-10-14 | ELEC TECH [480 h] | 21,919.2 | 21,859.2 | 10929.6 | 21859.2 | ELOUADRHIRI L | 1 | 1 | H | LATIFA E | Pat | 11-005 | HBI |  |  | 12-013 |  |  |  |  |  |  |  |  |  |  |  |  |  |  | OPC A |  |  |  |  |  |

Notes:
- 142211240: Explanation: crates (2 @ $9,016) $18,032, controller cards (2 @ / $4075) $8150(includes 30% volume increase)
- 142211265: Explanation: Engineering estimate based on quotes, ~$3k for the current / PCI DAQ board setup. SCM to contain multiple data connectors, a larger / FPGA, and additional connectors to DAQ, thus $6k per board. 5 boards / needed for 1st article.
- 142211175: Explanation: DAq boards (PTA $1365.68, PMC $1334.96, Adapter / $322.11) $3023, PCB assembly (5 @ $1267.40) $6337, PCB / assembly $2459, PCB assembly (5 @ $1622.72) $8114, PMC board assembly (5 @ / $520.18) $2601, PMC/PTA adapter (5 @ $485.20) $2426, prototype board $1025 / Steps: wafers
- 142211220: Explanation: HV modules (2 @ $9911) $19,822, MPOD module (3 @ $2912) $8736 (also / includes a 30% volume increase)
- 142211275: Steps: VSCM Firmware Development (done); VSCM Driver Development (done); VSCM CODA Integration (done); VSCM+DAQ Integration Testing (done)
- 142211275a: Steps: VSCM Firmware Development (done); VSCM Driver Development (done); VSCM CODA Integration (done); VSCM+DAQ Integration Testing (done)
- 142211365: Explanation: cable (1000') $2821.55, cable (1000') $795.73, connectors / (1400 @ 0.0773) $108.26, connectors single row (212 @ 0.526) $111.51, straight / plug conncetor 37 pin (106 @ 124.13) $13,157.78, straight plug / conncetor 51 pin (106 @ 181.36) $19224.16
- 142211530: Explanation: cable (1000') $2821.55, cable (1000') $795.73, connectors / molex (650 @ 0.087) $57.00, connectors single row (100 @ 0.526) $52.60, straight / plug conncetor 37 pin (48 @ 124.13) $5958.24, straight plug / conncetor 51 pin (48 @ 181.36) $8705.28
- 142211375: Explanation: power supply (6 @ $9911) $59,466, MPOD module (9 @ $2912) $26,208,
- 142211510: Explanation: HFCB (24 boards @ $1125) $27,000, setup $1400, testing $650, connectors / (48 @ $4.887) $234.58, connectors (24 @ $122.10) $2930.40, connectors (24 @ / $180.54) $4332.96, additional board parts (24 @21.67) $520.08
- 142211360: Explanation: HFCB boards (63 @ $625) $39,375, setup $1400, electrical test / $650, connector head (126 @ $3.2578) $410.48, SMT conn. 37 pin (63 @ / $122.10) $7962.30, SMT conn. 51 pin (63 @ $180.54) $11,374.02, / additional board parts (63 @ $21.67) $1365.21
- 142211515: Explanation: total PCB assembly
- 142211550: Explanation: Engineering estimate based on quotes, ~$3k for the current / PCI DAQ board setup. SCM to contain multiple data connectors, a larger / FPGA, and additional connectors to DAQ, thus $6k per board. 6 boards / needed for BST R4. (24 modules with 4 modules per SCM)
- 142211180: Explanation: Engineering estimate based on quotes, ~$3k for the current / PCI DAQ board setup. Final version will be bigger PCBs with / additional VME circuitry, thus $6k per board. 3 boards needed for BST / regions 1-3.
- 142211230: Explanation: HV modules (2 @ $8877) $17,754, crates (2 @ / $8402) $16,804 (also includes a 30% volume increase)
- 142211540: Explanation: power supply (4 @ $9911) $39,644, MPOD module (6 @ 2912) / $17,472
- 142211365a: Explanation: cable (1000') $2821.55, cable (1000') $795.73, connectors / (1400 @ 0.0773) $108.26, connectors single row (212 @ 0.526) $111.51, straight / plug conncetor 37 pin (106 @ 124.13) $13,157.78, straight plug / conncetor 51 pin (106 @ 181.36) $19224.16
- 142211390: Explanation: analog module $511.97, input module $511.97, 8-slot / backplane $608.75, LabVIEW real-time/Ethernet controller $1837.85, NI standard / system assurance program $250, PS-4 power supply $240.98, connector block (2 @ / 163.56) $327.12, LabVIEW real-time module $2515.31, optical module / $24,765
- 142211435: Explanation: Engineering estimate based on quotes, ~$3k for the current / PCI DAQ board setup. SCM to contain multiple data connectors, a larger / FPGA, and additional connectors to DAQ, thus $6k per board. 16 boards / needed for BST R1-R3. (63 modules with 4 modules per SCM)
