# October 13 Progress 12 GeV CR13-015,14-001

Schedule from Primavera P6, 2004-03-31 to 2017-12-19, data date 2013-10-31, costs in USD, A marks actual dates.
CHANGE REQUESTS INCLUDED / FY07 002, 003, 006, 007, 008, 010, 005, 009, 014, 012, 15, / 17, 18, 29-33 / FY08 / 001,002,003,005,004,011,014,013,009,016,018,017,019,020,24N/C,23,10,25,21,22,27,28,26,31,29,32,33,34,35, / 36,37,38,39,40,41,42,44,43,45,46,48,49,51,50,52,54,55,56, 57 ,58,59,60 / FY09 003, 002, 004, 005, 007, 008, 009, 010, 011, 012, / 14A-G,16,17,15,23, / 26,22,24,31,35,34,33,32,27,28,36,30,37,38,43,40,46,41,47,48,44,43A,49,52,51,39,42,53,64,66,61,71,70,67,63,01VA / FY10 001A-E,002, 005 ,003,004, / 008,007,010,011,012,18,23,12A,035,036,22,32,33,34,20,21,29,37,24,26,9,19,30,27,41,38,40,43,39,44,16,45,25,28,31, / 14,46,48,52,53,54,56,55,42,57,47,17,15,62,59,64,66,61,71,70,67,63,VA1,60,65,73 / FY11 / 001,002,007,003,010,016,011,014,15,19,09,17,18,12,13,20,06,08,22,23,VA2,VA3,26,24,27,31,28,30,29,38,25,32,37,46,47,35,40,43,42,44,41,22a,49,52,51,005,48,39,36,55,57,54,53 / FY12 001-A&D, / 005,002,003,007,010,009,011,008,012,014,015,016,17,13,22,25,18,23,21,26,24,29,28,27,29A,34,37,38,35,36,32,39,42,44,45,43,50,46,47,53,51,54,49,55 / FY13 001D,003,008,009,002,004,005,12,06,11,14,15,16 / This project is to be used to develop the new DOE guidance schedule / Mark Wiseman's PED corrections have been made - RKC / Implemented IPLs with 6 GeV / Hardening Schedule- 27 August 08 PMK
Must finish by 2017-09-30

| ID | Activity | Type | Duration | Start | Finish | Predecessors | Complete | Remaining | Planned start | Planned finish | Total float | Free float | Calendar | Resources | Cost | Actual cost | Calculated Remaining Total Cost | MONTHLY EV COST | RESP - Responsibility | STRT%COMP for CM EVM | FNSH%COMP for CM EVM | EVMS Reporting Codes | CAM RESPONSIBLE | Activities with Steps | Pat's Code | CR 11-005 | SVT | CR 11-058 | CR 12-013 | OPC Allison | Remaining Material Cost Based on % Compl | Claimed Material Cost Based on % Complet | Initial Claimed Material Calc | Claimed Material Divider | CR 12-027 | CR 12-054 | CR 12-053 | MARCH!!! | ReBaseline Actuals Adjustment | LOE Divider | LOE Multiplier | Original Activity ID Rebaseline | PRIOR MONTH EV COST | CR 07-024 | CR 11-026 | CR 11-035 | BOE Expenses | CR 13-015 | Post Rebaseline | CR 12-001 | BOE Labor | CR 13-002 | BOE Procurement | Obligated Prior to Rebaseline | CR 12-055 | CR 14-001 | LOE % Pre Calc | LOE % |
| --- | --- | --- | --- | --- | --- | --- | --- | --- | --- | --- | --- | --- | --- | --- | --- | --- | --- | --- | --- | --- | --- | --- | --- | --- | --- | --- | --- | --- | --- | --- | --- | --- | --- | --- | --- | --- | --- | --- | --- | --- | --- | --- | --- | --- | --- | --- | --- | --- | --- | --- | --- | --- | --- | --- | --- | --- | --- | --- |
| 142211445 | BST R1-R3 HBI - 9 DAq-SCM (3) develop program and test (2/2) - Labor |  | 208d | 2013-05-03 A | 2013-08-30 A | 142211440 FS-33d | 100% |  | 2013-06-03 | 2014-04-04 |  |  |  | SCIENTIST [400 h]; ELEC ENG [400 h] | 59,374.46 | 58,268 | 58268 | 58268 | ELOUADRHIRI L | 1 | 1 | S | LATIFA E | ST | Pat | 11-005 | HBI | 11-058 | 12-013 | OPC A |  |  |  |  |  |  |  |  |  |  |  |  |  |  |  |  |  |  |  |  |  |  |  |  |  |  |  |  |
| 142211335 | BST R1-R3 MECH GRP - Modules: Granite table, mounting, and alignment fixture (1) procurement - Proc |  | 45d | 2013-07-01 A | 2013-08-30 A | 142211330, 9-130M FS+120d | 100% |  | 2013-08-01 | 2013-10-03 |  |  |  | PROCUREMENT<$50K 60 | 9,837.1 |  | 9837.1 | 9837.1 | ELOUADRHIRI L | 1 | 1 | D | LATIFA E |  | Pat | 11-005 | MECH | 11-058 | 12-013 |  | 0 | 9837.1 | 983710 | 100 | 12-027 | 12-054F |  |  |  |  |  |  |  |  |  |  |  |  |  |  |  |  |  |  |  |  |  |  |
| 142211340 | BST R1-R3 MECH GRP - 3: Modules: round table, mounting, and alignment fixture (2) construction - Labor |  | 10d | 2013-07-08 A | 2013-08-30 A | 9-120M FS+76d, 142211335 FS-45d | 100% |  | 2013-10-03 | 2013-10-16 |  |  |  | MECH TECH [80 h] | 3,785.6 | 3,668.8 | 3555.2 | 3555.2 | ELOUADRHIRI L | 1 | 1 | H | LATIFA E |  | Pat | 11-005 | MECH | 11-058 | 12-013 |  |  |  |  |  | 12-027 | 12-054F |  |  |  |  |  |  |  |  |  |  |  |  |  |  |  |  |  |  |  |  |  |  |
| 142211350 | BST R1-R3 MECH GRP - 3: Modules 1st article stave tests mount & aligning of modules in model of cold plate - Labor FY12 |  | 24d | 2013-08-30 A | 2013-08-30 A | 142211460 FS-130d, 142211225 FS+144d, 142211300, 142211245, 142211230 FS+18d, 142211340, 142211320 | 100% |  | 2013-10-10 | 2013-11-12 |  |  |  | MECH ENG [40 h]; MECH TECH [200 h] | 12,450.8 | 12,066.4 | 12066.4 | 12066.4 | ELOUADRHIRI L | 1 | 1 | H | LATIFA E |  | Pat | 11-005 | MECH | 11-058 | 12-013 | OPC A |  |  |  |  |  | 12-054 | 12-053 |  |  |  |  |  |  |  |  |  |  |  |  |  |  |  |  |  |  |  |  |  |
| 142211350M | End of 1st Article Program | milestone | 0d | 2013-08-30 A | 2013-08-30 A | 142211160p | 100% |  | 2013-09-03 | 2013-09-03 |  |  |  |  |  |  |  | 0 | ELOUADRHIRI L | 1 | 1 | M | LATIFA E |  | Pat | 11-005 | MECH | 11-058 | 12-013 | OPC A |  |  |  |  |  | 12-054 |  | XX |  |  |  |  |  |  |  |  |  |  |  |  |  |  |  |  |  |  |  |  |
| 142211460 | BST R1-R3 MECH GRP - Cooling system: procurement - proc |  | 54d | 2013-08-30 A | 2013-08-30 A | 142211455 | 100% |  | 2013-09-19 | 2013-12-05 |  |  |  | PROCUREMENT<$50K 60 | 7,739.25 |  | 7739.25 | 7739.25 | ELOUADRHIRI L | 1 | 1 | D | LATIFA E |  | Pat | 11-005 | MECH | 11-058 | 12-013 | OPC A | 0 | 7739.25 | 773925 | 100 |  | 12-054F |  |  |  |  |  |  |  |  |  |  |  |  |  |  |  |  |  |  |  |  |  |  |
| 142211800 | Installation MECH GRP - Support and alignment tube (1) to mount solenoid, MFG Drawings (incl. alignment system) - Labor |  | 97d | 2013-08-30 A | 2013-08-30 A | 9-130M FS+23d, 142211350 | 100% |  | 2013-11-13 | 2014-04-10 |  |  |  | MECH ENG [75.05 h]; MECH DES [150.1 h] | 13,304.11 | 12,892.09 | 13742.4 | 12892.089 | ELOUADRHIRI L | 1 | 1 | H | LATIFA E |  | Pat | 11-005 | MECH | 11-058 |  | OPC A |  |  |  |  |  | 12-054 |  |  |  |  |  |  |  |  |  |  |  |  |  |  |  |  |  |  |  |  |  |  |
| 142211845 | Installation MECH GRP - Installation cart: (2) procurement prep - Labor |  | 21d | 2013-08-30 A | 2013-08-30 A | 142211840 FS-31d | 100% |  | 2013-09-03 | 2013-10-01 |  |  |  | MECH ENG [40 h] | 2,898.8 | 2,894.4 | 2894.4 | 2894.4 | ELOUADRHIRI L | 1 | 1 | H | LATIFA E |  | Pat | 11-005 | MECH |  |  | OPC A |  |  |  |  |  |  |  |  |  |  |  |  |  |  |  |  |  |  |  |  |  |  |  |  |  |  |  |  |
| 142211850 | Installation MECH GRP - Installation cart: (3) construction - Proc |  | 22d | 2013-08-30 A | 2013-08-30 A | 142211845 | 100% |  | 2013-10-02 | 2013-10-31 |  |  |  | PROCUREMENT<$50K 60 | 15,972.26 |  | 15972.26 | 15972.26 | ELOUADRHIRI L | 1 | 1 | D | LATIFA E |  | Pat | 11-005 | MECH |  |  | OPC A | 0 | 15972.26 | 1597226 | 100 |  |  |  |  |  |  |  |  |  |  |  |  |  |  |  |  |  |  |  |  |  |  |  |  |
| 142211855 | Installation MECH GRP - Installation cart: (4) construction - Labor |  | 21d | 2013-08-30 A | 2013-08-30 A | 142211850 | 100% |  | 2013-11-01 | 2013-12-03 |  |  |  | MECH TECH [80 h] | 3,785.6 | 3,668.8 | 3668.8 | 3668.8 | ELOUADRHIRI L | 1 | 1 | H | LATIFA E |  | Pat | 11-005 | MECH |  |  | OPC A |  |  |  |  |  |  |  |  |  |  |  |  |  |  |  |  |  |  |  |  |  |  |  |  |  |  |  |  |
| 142211860 | Installation MECH GRP - Purging system: (1) procurement prep - Labor |  | 21d | 2013-08-30 A | 2013-08-30 A | 9-130M, 9-140M | 100% |  | 2013-10-01 | 2013-10-29 |  |  |  | MECH ENG [40 h] | 2,986.8 | 2,894.4 | 2894.4 | 2894.4 | ELOUADRHIRI L | 1 | 1 | H | LATIFA E |  | Pat | 11-005 | MECH |  |  | OPC A |  |  |  |  |  |  |  |  |  |  |  |  |  |  |  |  |  |  |  |  |  |  |  |  |  |  |  |  |
| 142211865 | Installation MECH GRP - Purging system: (2) installation - Proc |  | 21d | 2013-08-30 A | 2013-08-30 A | 142211860 | 100% |  | 2013-10-30 | 2013-11-27 |  |  |  | PROCUREMENT<$50K 60 | 5,324.09 |  | 5324.09 | 5324.09 | ELOUADRHIRI L | 1 | 1 | D | LATIFA E |  | Pat | 11-005 | MECH |  |  | OPC A | 0 | 5324.09 | 532409 | 100 |  |  |  |  |  |  |  |  |  |  |  |  |  |  |  |  |  |  |  |  |  |  |  |  |
| 142211870 | Installation MECH GRP - Purging system: (3) installation - Labor |  | 21d | 2013-08-30 A | 2013-08-30 A | 142211865 | 100% |  | 2013-12-02 | 2014-01-07 |  |  |  | MECH DES [40 h]; MECH ENG [40 h]; MECH TECH [80 h] | 8,824.4 | 8,551.6 | 8551.6 | 8551.6 | ELOUADRHIRI L | 1 | 1 | H | LATIFA E |  | Pat | 11-005 | MECH |  |  | OPC A |  |  |  |  |  |  |  |  |  |  |  |  |  |  |  |  |  |  |  |  |  |  |  |  |  |  |  |  |
| 142211950 | Re-Baseline Actuals Adjustment |  | 1d | 2013-08-30 A | 2013-08-30 A |  | 100% |  | 2013-09-03 | 2013-09-03 |  |  |  | PROCUREMENT>$50K 69 NO ESCALATION | -297,961.97 |  |  |  |  |  |  |  |  |  |  |  |  |  |  |  |  |  |  | 100 |  |  |  |  | ADJ |  |  |  |  |  |  |  |  |  |  |  |  |  |  |  |  |  |  |  |
| 242211013E | SVT-FY13 Travel |  | 20d | 2013-09-03 A | 2013-09-30 A | 9-130M FS+228d | 100% |  | 2013-10-01 | 2013-10-28 |  |  | 8/5 M-F w/JLAB Holidays ReBaseline | TRAVEL | 4,502.95 |  |  | 0 | ELOUADRHIRI L | 1 | 1 | E | LATIFA E |  |  | 11-005 |  |  | 12-013 |  |  |  |  |  |  |  |  |  |  | 100 | 100 | 242211013E | 4502.95 | 07-024 | 11-026 | 11 -035 | PE | 13-015 | PR |  |  |  |  |  |  |  |  |  |
| 242211130 | HBI - SVT Engineering and Construction Oversight FY13 |  | 20d | 2013-09-03 A | 2013-09-30 A | 9-130M FS+228d | 100% |  | 2013-10-01 | 2013-10-28 |  |  | 8/5 M-F w/JLAB Holidays ReBaseline | SCIENTIST [103.17 h] | 7,756.32 | 7,516.97 |  | 0 | ELOUADRHIRI L | 1 | 1 | E | LATIFA E |  | Pat | 11-005 | HBI |  |  |  |  |  |  |  |  |  |  |  |  | 100 | 100 | 242211130 | 7516.9662 |  |  |  |  | 13-015 | PR | 12-001 | PE |  |  |  |  |  |  |  |
| 242211160t | FNAL Construction and test (Jlab/FNAL) of R1-R3 production modules (60 modules) Part A |  | 182d | 2013-09-03 A | 2014-03-11 | 242211610a FS-114d, 242211890 FS-375d, 242211610 FS-114d, 242211515 FS-325d, 242211520 FS-325d, 9-130M FS+228d, 242211885 FS-375d | 85% | 82d | 2013-10-01 | 2014-06-27 | 329d | 100d | 8/5 M-F w/JLAB Holidays ReBaseline | PROCUREMENT>$50K 69 NO ESCALATION | 22,828 |  |  | 0 | ELOUADRHIRI L | 1 | 1 | D | LATIFA E |  | Pat | 11-005 |  | 11-058 | 12-013 |  | 3424.2 | 19403.8 | 1940380 | 100 |  |  |  |  |  |  |  | 242211160t | 19403.8 |  |  |  |  | 13-015 | PR |  |  | 13-002F | OB | OB |  |  |  |  |
| 242211160u | FNAL Construction and test (Jlab/FNAL) of R1-R3 production modules (60 modules) Part B |  | 182d | 2013-09-03 A | 2014-05-30 | 242211160t FS-182d |  | 139d | 2013-10-01 | 2014-06-27 | 276.75d | 43d | 8/5 M-F w/JLAB Holidays ReBaseline | PROCUREMENT<$50K 60 NO ESCALATION; PROCUREMENT>$50K 69 NO ESCALATION | 222,139.05 |  |  | 0 | ELOUADRHIRI L | 1 | 1 | D | LATIFA E |  | Pat | 11-005 |  | 11-058 | 12-013 |  | 222139.05 | 0 | 0 | 100 |  |  |  |  |  |  |  | 242211160u |  |  |  |  |  | 13-015 | PR |  |  | 13-002F | OB | OB |  |  |  |  |
| 242211160w | FNAL Construction and test (Jlab/FNAL) of R4 production modules Phase 1 |  | 267d | 2013-09-03 A | 2014-09-30 | 242211520 FS-325d, 242211160u FS-182d, 242211515 FS-325d |  | 224d | 2013-10-01 | 2014-10-28 | 305d | 76d | 8/5 M-F w/JLAB Holidays ReBaseline | PROCUREMENT>$50K 69 NO ESCALATION FY14 | 46,506.36 |  |  | 0 | ELOUADRHIRI L | 1 | 1 | D | LATIFA E |  | Pat | 11-005 |  | 11-058 | 12-013 |  | 46506.36 | 0 | 0 | 100 |  |  |  |  |  |  |  | 242211160w |  |  |  |  |  | 13-015 | PR |  |  | 13-002F | OB | OB |  |  |  |  |
| 242211335 | MECH GRP - Modules: asssembly table, mounting, and alignment fixture procurement - Proc |  | 9d | 2013-09-03 A | 2013-09-10 A | 9-130M FS+228d | 100% |  | 2013-10-01 | 2013-10-11 |  |  | 8/5 M-F w/JLAB Holidays ReBaseline | PROCUREMENT<$50K 60 | 1,289.7 |  |  | 0 | ELOUADRHIRI L | 1 | 1 | D | LATIFA E |  | Pat | 11-005 | MECH | 11-058 | 12-013 |  | 0 | 1289.7 | 128970 | 100 | 12-027 | 12-054F |  |  |  |  |  | 242211335 | 1289.7 |  |  |  |  | 13-015 | PR |  |  | 13-002F | CP | OB-2 |  |  |  |  |
| 242211360 | HBI - Electronics HFCB R1-R4 - Proc |  | 139d | 2013-09-03 A | 2014-03-31 | 9-130M FS+228d |  | 96d | 2013-10-01 | 2014-04-28 | 305d | 0d | 8/5 M-F w/JLAB Holidays ReBaseline | PROCUREMENT<$50K 60 NO ESCALATION FY14; PROCUREMENT>$50K 69 NO ESCALATION FY14 | 101,920 |  |  | 0 | ELOUADRHIRI L | 1 | 1 | U | LATIFA E |  | Pat | 11-005 | HBI | 11-058 | 12-013 |  | 101920 | 0 | 0 | 100 |  | 12-054F |  |  |  |  |  | 242211360 |  |  |  |  |  | 13-015 | PR |  |  | 13-002F | OB | OB |  |  |  |  |
| 242211361 | HBI - Electronics HFCB R1-R4 - Proc First Article 6 cables |  | 14d | 2013-09-03 A | 2013-12-20 | 9-130M FS+228d |  | 34d | 2013-10-01 | 2013-10-18 | 470d | 0d | 8/5 M-F w/JLAB Holidays ReBaseline | PROCUREMENT>$50K 69 | 7,350 |  |  | 0 | ELOUADRHIRI L | 1 | 1 | U | LATIFA E |  | Pat | 11-005 | HBI | 11-058 | 12-013 |  | 7350 | 0 | 0 | 100 |  | 12-054F |  |  |  |  |  | 242211361 |  |  |  |  |  | 13-015 | PR |  |  | 13-002F | OB | OB |  |  |  |  |
| 242211365a | HBI - Cable assemblies: HV, LV, and data - Proc |  | 98d | 2013-09-03 A | 2014-03-05 | 9-130M FS+228d | 13% | 78d | 2013-10-01 | 2014-02-28 | 299.75d | 99.75d | 8/5 M-F w/JLAB Holidays ReBaseline | PROCUREMENT<$50K 60 NO ESCALATION FY14 | 80,925 |  |  | 0 | ELOUADRHIRI L | 1 | 1 | U | LATIFA E |  | Pat | 11-005 | HBI |  | 12-013 |  | 70105.3275 | 10819.6725 | 1081967.25 | 100 |  |  |  |  |  |  |  | 242211365a | 10819.6725 |  |  |  |  | 13-015 | PR |  |  | 13-002F | OB | OB | 12-055 |  |  |  |
| 242211367 | HBI - Cable assemblies: Pulser |  | 139d | 2013-09-03 A | 2014-05-01 | 9-130M FS+228d |  | 119d | 2013-10-01 | 2014-04-28 | 258.75d | 58.75d | 8/5 M-F w/JLAB Holidays ReBaseline | PROCUREMENT<$50K 60 NO ESCALATION FY14 | 19,640.4 |  |  | 0 | ELOUADRHIRI L | 1 | 1 | U | LATIFA E |  | Pat | 11-005 | HBI |  | 12-013 |  | 19640.4 | 0 | 0 | 100 |  |  |  |  |  |  |  | 242211367 |  |  |  |  |  | 13-015 | PR |  |  | 13-002F | OB | OB | 12-055 |  |  |  |
| 242211370 | HBI - Cable assemblies: HV, LV, and data fabrication and testing R1-R4 - Labor FY13 |  | 182d | 2013-09-03 A | 2014-05-30 | 9-130M FS+228d | 12% | 139d | 2013-10-01 | 2014-06-27 | 249d | 23d | 8/5 M-F w/JLAB Holidays ReBaseline | ELEC TECH [21.98 h] | 1,032.84 | 240.52 |  | 120.116304 | ELOUADRHIRI L | 1 | 1 | S | LATIFA E | ST | Pat | 11-005 | HBI |  | 12-013 |  |  |  |  |  |  |  |  |  |  |  |  | 242211370 |  |  |  |  |  | 13-015 | PR |  | PE | 13-002F |  |  |  |  |  |  |
| 242211370a | HBI - Cable assemblies: HV, LV, and data fabrication and testing R1-R4 - Labor FY14 |  | 162d | 2013-09-03 A | 2014-05-30 | 242211370 FS-162d | 12% | 139d | 2013-10-01 | 2014-05-30 | 249d | 49d | 8/5 M-F w/JLAB Holidays ReBaseline | ELEC TECH [178.02 h] | 8,365.16 | 1,948.02 |  | 1003.819176 | ELOUADRHIRI L | 1 | 1 | S | LATIFA E | ST | Pat | 11-005 | HBI |  | 12-013 |  |  |  |  |  |  |  |  |  |  |  |  | 242211370 |  |  |  |  |  | 13-015 | PR |  | PE | 13-002F |  |  |  | 14-001 |  |  |
| 242211380 | HBI - Sloco: HV, LV, PS distribution system (fabricate) - Labor |  | 11d | 2013-09-03 A | 2013-10-21 A | 9-140M | 100% |  | 2013-11-01 | 2013-11-15 |  |  | 8/5 M-F w/JLAB Holidays ReBaseline | ELEC TECH [30 h] | 1,409.7 | 1,398.4 |  | 704.85 | ELOUADRHIRI L | 1 | 1 | H | LATIFA E |  | Pat | 11-005 | HBI |  | 12-013 |  |  |  |  |  |  |  |  |  |  |  |  | 242211380 | 704.85 |  |  |  |  | 13-015 | PR |  | PE | 13-002F |  |  |  | 14-001 |  |  |
| 242211405a | Obligated Procured Labor for Activity 242211405 |  | 99d | 2013-09-03 A | 2013-09-23 A | 9-130M FS+228d | 100% |  | 2013-10-01 | 2014-03-03 |  |  | 8/5 M-F w/JLAB Holidays ReBaseline | PROCUREMENT>$50K 69 NO ESCALATION FY14 | 1,792 |  |  | 0 | ELOUADRHIRI L | 1 | 1 | D | LATIFA E |  | Pat | 11-005 | MECH |  |  |  | 0 | 1792 | 179200 | 100 | 12-027F | 12-054F |  |  |  |  |  | 242211405 | 1792 |  |  |  | PE | 13-015 | PR |  | PE | 13-002F |  | OB |  |  |  |  |
| 242211465 | MECH GRP - Support, cooling, coldplate, and alignment of stave: manufacturing Drawings - Labor |  | 14d | 2013-09-03 A | 2013-09-20 A | 9-130M FS+228d | 100% |  | 2013-10-01 | 2013-10-18 |  |  | 8/5 M-F w/JLAB Holidays ReBaseline | PLABOR; MECH ENG [20 h] | 5,973.4 | 1,447.2 |  | 0 | ELOUADRHIRI L | 1 | 1 | S | LATIFA E | ST | Pat | 11-005 | MECH | 11-058 | 12-013 |  |  |  |  |  |  | 12-054 |  |  |  |  |  | 242211465 | 5927.2 |  |  |  | PE | 13-015 | PR |  | PE | 13-002F |  |  |  |  |  |  |
| 242211490 | HBI - Module R1-R4 : quality assurance, test, and burn-in at FNAL - Labor FY13 |  | 267d | 2013-09-03 A | 2014-09-30 | 242211160w5 FS-300d, 242211160w FS-300d, 242211160t FS-182d, 242211160u FS-186.75d | 8% | 224d | 2013-10-01 | 2014-10-28 | 229d | 0d | 8/5 M-F w/JLAB Holidays ReBaseline | ELEC ENG [66.67 h]; ELEC TECH [66.67 h]; VISTNG USERS [134.83 h] | 10,917.32 | 2,009.02 |  | 246.50697539 | ELOUADRHIRI L | 1 | 1 | U | LATIFA E |  | Pat | 11-005 | HBI | 11-058 |  |  |  |  |  |  |  | 12-054 |  |  |  |  |  | 242211490 | 634.7819109 |  |  |  |  | 13-015 | PR |  | PE | 13-002F |  |  |  |  |  |  |
| 242211490a | HBI - Module R1-R4 : quality assurance, test, and burn-in at FNAL - Labor FY14 |  | 247d | 2013-09-03 A | 2014-09-30 | 242211490 FS-247d | 8% | 224d | 2013-10-01 | 2014-09-30 | 229d | 0d | 8/5 M-F w/JLAB Holidays ReBaseline | ELEC TECH [823.33 h]; VISTNG USERS [1665.17 h]; ELEC ENG [823.33 h] | 134,831.48 | 21,402.1 |  | 3141.57353185 | ELOUADRHIRI L | 1 | 1 | U | LATIFA E |  | Pat | 11-005 | HBI | 11-058 |  |  |  |  |  |  |  | 12-054 |  |  |  |  |  | 242211490 | 8089.88892324 |  |  |  |  | 13-015 | PR |  | PE | 13-002F |  |  |  | 14-001 |  |  |
| 242211515 | HBI - Electronics: HFCB Population - Proc Part A |  | 161d | 2013-09-03 A | 2014-04-30 | 242211360 FS-139d | 9% | 118d | 2013-10-01 | 2014-05-29 | 512d | 207d | 8/5 M-F w/JLAB Holidays ReBaseline | PROCUREMENT<$50K 60 NO ESCALATION FY14 | 24,520.2 |  |  | 0 | ELOUADRHIRI L | 1 | 1 | U | LATIFA E |  | Pat | 11-005 | HBI | 11-058 | 12-013 |  | 22234.91736 | 2285.28264 | 228528.264 | 100 |  | 12-054F |  |  |  |  |  | 242211515 | 2285.28264 |  |  |  |  | 13-015 | PR |  |  | 13-002F | VQ | OB |  |  |  |  |
| 242211530 | HBI - Compunetics HFCB Bend Test - Proc |  | 20d | 2013-09-03 A | 2013-09-23 A | 9-130M FS+228d, 242211361 FS-14d | 100% |  | 2013-10-01 | 2013-10-28 |  |  | 8/5 M-F w/JLAB Holidays ReBaseline | PROCUREMENT<$50K 60 | 200 |  |  | 0 | ELOUADRHIRI L | 1 | 1 | D | LATIFA E |  | Pat | 11-005 | HBI | 11-058 | 12-013 |  | 0 | 200 | 20000 | 100 |  | 12-054F |  |  |  |  |  | 242211530 | 200 |  |  |  |  | 13-015 | PR |  |  | 13-002F | OB | OB |  |  |  |  |
| 242211605 | HBI - Bus cable PCB production - Proc |  | 62d | 2013-09-03 A | 2013-11-27 | 9-130M FS+228d | 21% | 19d | 2013-10-01 | 2014-01-08 | 450d | 41d | 8/5 M-F w/JLAB Holidays ReBaseline | PROCUREMENT<$50K 60 NO ESCALATION FY14 | 22,550 |  |  | 947.1 | ELOUADRHIRI L | 1 | 1 | D | LATIFA E |  | Pat | 11-005 | MECH | 11-058 |  |  | 17843.815 | 4706.185 | 470618.5 | 100 |  | 12-054 |  |  |  |  |  | 242211605 | 3759.085 |  |  |  |  | 13-015 | PR |  |  | 13-002F | OB | OB |  |  |  |  |
| 242211610 | HBI - Bus cable PCB receive and Test - Labor FY13 |  | 75d | 2013-09-03 A | 2013-12-20 | 242211605 FS-60d | 50% | 34d | 2013-10-01 | 2014-01-28 | 409d | 26d | 8/5 M-F w/JLAB Holidays ReBaseline | ELEC TECH [9.6 h] | 451.1 | 248.3 |  | 0 | ELOUADRHIRI L | 1 | 1 | H | LATIFA E |  | Pat | 11-005 | MECH | 11-058 |  |  |  |  |  |  |  | 12-054 |  |  |  |  |  | 242211610 | 218.592 |  |  |  |  | 13-015 | PR |  | PE | 13-002F |  |  |  |  |  |  |
| 242211610a | HBI - Bus cable PCB receive and Test - Labor FY14 |  | 57d | 2013-09-03 A | 2013-12-20 | 242211610 FS-60d | 50% | 34d | 2013-10-01 | 2013-12-20 | 409d | 80d | 8/5 M-F w/JLAB Holidays ReBaseline | ELEC TECH [30.4 h] | 1,428.5 | 786.28 |  | 0 | ELOUADRHIRI L | 1 | 1 | H | LATIFA E |  | Pat | 11-005 | MECH | 11-058 |  |  |  |  |  |  |  | 12-054 |  |  |  |  |  | 242211610 | 714.248 |  |  |  |  | 13-015 | PR |  | PE | 13-002F |  |  |  | 14-001 |  |  |
| 242211620 | FNAL Tooling |  | 20d | 2013-09-03 A | 2013-09-23 A | 9-130M FS+228d | 100% |  | 2013-10-01 | 2013-10-28 |  |  | 8/5 M-F w/JLAB Holidays ReBaseline | PROCUREMENT<$50K 60 | 6,259.1 |  |  | 0 | ELOUADRHIRI L | 1 | 1 | D | LATIFA E |  | Pat | 11-005 | MECH | 11-058 |  |  | 0 | 6259.1 | 625910 | 100 |  | 12-054 |  |  |  |  |  | 242211605 | 6259.1 |  |  |  |  | 13-015 | PR |  |  | 13-002F | OB | OB |  |  |  |  |
| 242211670 | INFRA STR - Integrated Humidity Reduction System for SVT Control room - Proc |  | 43d | 2013-09-03 A | 2013-12-20 | 9-130M FS+228d | 82% | 34d | 2013-10-01 | 2013-12-02 | 419d | 219d | 8/5 M-F w/JLAB Holidays ReBaseline | PROCUREMENT<$50K 60 NO ESCALATION FY14 | 4,661.78 |  |  | 338.911406 | ELOUADRHIRI L | 1 | 1 | D | LATIFA E |  | Pat | 11-005 | MECH | 11-058 |  |  | 845.180714 | 3816.599286 | 381659.9286 | 100 |  | 12-054 |  |  |  |  |  | 242211670 | 3477.68788 |  |  |  |  | 13-015 | PR |  |  | 13-002F | PE | OB |  |  |  |  |
| 242211705 | MECH GRP - Tooling for assembly and repairs: manufacturing Drawings - Labor/Expenses FY13 |  | 31d | 2013-09-03 A | 2013-10-21 A | 9-130M FS+228d | 100% |  | 2013-10-01 | 2013-11-12 |  |  | 8/5 M-F w/JLAB Holidays ReBaseline | PLABOR; MECH ENG [12.9 h] | 3,275.5 | 953.63 |  | 1622.852 | ELOUADRHIRI L | 1 | 1 | H | LATIFA E |  | Pat | 11-005 | MECH | 11-058 |  |  |  |  |  |  |  | 12-054 |  |  |  |  |  | 242211705 | 1622.852 |  |  |  | PE | 13-015 | PR |  | PE | 13-002F |  |  |  |  |  |  |
| 242211705a | MECH GRP - Tooling for assembly and repairs: manufacturing Drawings - Labor/Expenses FY14 |  | 11d | 2013-09-03 A | 2013-10-21 A | 242211705 FS-10d | 100% |  | 2013-10-01 | 2013-10-15 |  |  | 8/5 M-F w/JLAB Holidays ReBaseline | PLABOR; MECH ENG [7.1 h] | 1,842.47 | 524.19 |  | 921.2335 | ELOUADRHIRI L | 1 | 1 | H | LATIFA E |  | Pat | 11-005 | MECH | 11-058 |  |  |  |  |  |  |  | 12-054 |  |  |  |  |  | 242211705 | 921.2335 |  |  |  | PE | 13-015 | PR |  | PE | 13-002F |  |  |  | 14-001 |  |  |
| 242211755 | HBI - Additional HFCB - Proc |  | 139d | 2013-09-03 A | 2014-03-31 | 9-130M FS+228d |  | 96d | 2013-10-01 | 2014-04-28 | 408d | 208d | 8/5 M-F w/JLAB Holidays ReBaseline | PROCUREMENT<$50K 60 NO ESCALATION FY14 | 39,100 |  |  | 0 | ELOUADRHIRI L | 1 | 1 | D | LATIFA E |  | Pat | 11-005 | MECH | 11-058 |  |  | 39100 | 0 | 0 | 100 |  | 12-054 |  |  |  |  |  | 242211755 |  |  |  |  |  | 13-015 | PR |  |  | 13-002F | PE | OB |  |  |  |  |
| 242211885 | MECH GRP - Module inserts Copper/PEEK Part A |  | 54d | 2013-09-03 A | 2013-09-23 A | 9-140M | 100% |  | 2013-10-01 | 2013-12-17 |  |  | 8/5 M-F w/JLAB Holidays ReBaseline | PROCUREMENT<$50K 60 | 2,734.54 |  |  | 0 | ELOUADRHIRI L | 1 | 1 | D | LATIFA E |  | Pat | 11-005 | MECH |  |  |  | 0 | 2734.54 | 273454 | 100 |  |  |  |  |  |  |  | 242211885 | 2734.54 |  |  |  |  | 13-015 | PR |  |  | 13-002F | PE | OB-2 |  | 14-001 |  |  |
| 242211470 | MECH GRP - Support, cooling, coldplate, and alignment of stave: procurement prep - Labor |  | 6d | 2013-09-16 A | 2013-10-21 A | 242211465 | 100% |  | 2013-10-01 | 2013-10-08 |  |  | 8/5 M-F w/JLAB Holidays ReBaseline | MECH ENG [8 h] | 597.36 | 592.15 |  | 289.44 | ELOUADRHIRI L | 1 | 1 | H | LATIFA E |  | Pat | 11-005 | MECH | 11-058 | 12-013 |  |  |  |  |  |  | 12-054 |  |  |  |  |  | 242211470 | 289.44 |  |  |  |  | 13-015 | PR |  | PE | 13-002F |  |  |  |  |  |  |
| 242211875 | MECH GRP - Construct silicon module shipping containers -Proc Part A |  | 98d | 2013-09-16 A | 2014-02-28 | 9-140M | 20% | 75d | 2013-10-01 | 2014-02-28 | 347d | 114d | 8/5 M-F w/JLAB Holidays ReBaseline | PROCUREMENT<$50K 60 | 21,892.79 |  |  | 4293.176119 | ELOUADRHIRI L | 1 | 1 | D | LATIFA E |  | Pat | 11-005 | MECH |  |  |  | 17599.613881 | 4293.176119 | 429317.6119 | 100 |  |  |  |  |  |  |  | 242211875 |  |  |  |  |  | 13-015 | PR |  |  | 13-002F | PE | OB-2 |  | 14-001 |  |  |
| 242211014E | SVT-FY14 Travel |  | 247d | 2013-10-01 A | 2014-09-30 | 242211013E | 9% | 224d | 2013-11-01 | 2014-10-31 | 719d | 0d | 8/5 M-F w/JLAB Holidays ReBaseline | TRAVEL | 34,259.08 |  |  | 3189.520348 | ELOUADRHIRI L | 1 | 1 | E | LATIFA E |  |  | 11-005 |  |  | 12-013 |  |  |  |  |  |  |  |  |  |  | 100 | 100 | 242211014E |  | 07-024 | 11-026 | 11 -035 | PE | 13-015 | PR |  |  |  |  |  |  | 14-001 | 90.6882591 | 9.31174089 |
| 242211140 | HBI - SVT Engineering and Construction Oversight FY14 |  | 247d | 2013-10-01 A | 2014-09-30 | 242211130 | 9% | 224d | 2013-11-01 | 2014-10-31 | 719d | 0d | 8/5 M-F w/JLAB Holidays ReBaseline | SCIENTIST [949.6 h] | 71,390.93 | 6,647.74 |  | 6646.4953968 | ELOUADRHIRI L | 1 | 1 | E | LATIFA E |  | Pat | 11-005 | HBI |  |  |  |  |  |  |  |  |  |  |  |  | 100 | 100 | 242211140 |  |  |  |  |  | 13-015 | PR | 12-001 | PE |  |  |  |  | 14-001 | 90.6882591 | 9.31174089 |
| 242211340 | MECH GRP - Modules: assembly table, mounting, and alignment fixture construction - Labor |  | 20d | 2013-10-01 A | 2013-10-21 A | 242211335 FS+14d | 100% |  | 2013-11-01 | 2013-12-02 |  |  | 8/5 M-F w/JLAB Holidays ReBaseline | MECH TECH [40 h] | 1,892.8 | 1,892.8 |  | 1892.8 | ELOUADRHIRI L | 1 | 1 | H | LATIFA E |  | Pat | 11-005 | MECH | 11-058 | 12-013 |  |  |  |  |  | 12-027 | 12-054F |  |  |  |  |  | 242211340 |  |  |  |  |  | 13-015 | PR |  | PE | 13-002F |  |  |  | 14-001 |  |  |
| 242211390 | HBI - Sloco: Slow controls for monitoring and charge calibration system: component procurement - Proc |  | 57d | 2013-10-01 A | 2014-02-04 | 9-140M FS+23d | 2% | 57d | 2013-11-01 | 2014-02-04 | 354d | 0d | 8/5 M-F w/JLAB Holidays ReBaseline | PROCUREMENT<$50K 60 | 67,644.14 |  |  | 1258.181004 | ELOUADRHIRI L | 1 | 1 | D | LATIFA E |  | Pat | 11-005 | HBI | 11-058 |  |  | 66385.958996 | 1258.181004 | 125818.1004 | 100 | 12-027 | 12-054 |  |  |  |  |  | 242211390 |  |  |  |  |  | 13-015 | PR |  |  | 13-002F | PE | OB-2 |  | 14-001 |  |  |
| 242211405 | MECH GRP - Faraday cage protective enclosure system Manufacturing Drawings - Labor |  | 79d | 2013-10-01 A | 2014-02-03 | 9-140M | 15% | 56d | 2013-11-01 | 2014-03-06 | 312d | 13d | 8/5 M-F w/JLAB Holidays ReBaseline | PLABOR; MECH ENG [40 h] | 3,911.38 | 869.57 |  | 586.707 | ELOUADRHIRI L | 1 | 1 | S | LATIFA E | ST | Pat | 11-005 | MECH |  |  |  |  |  |  |  | 12-027F | 12-054F |  |  |  |  |  | 242211405 |  |  |  |  | PE | 13-015 | PR |  | PE | 13-002F |  |  |  | 14-001 |  |  |
| 242211410 | MECH GRP - Faraday cage protective enclosure system specifications and procurement prep - Labor FY13 |  | 20d | 2013-10-01 A | 2014-02-13 | 242211405a FS-69d, 242211405 FS-69d | 50% | 64d | 2013-11-15 | 2013-12-16 | 299d | 0d | 8/5 M-F w/JLAB Holidays ReBaseline | MECH ENG [1.5 h] | 112.01 | 29.61 |  | 54.27 | ELOUADRHIRI L | 1 | 1 | H | LATIFA E |  | Pat | 11-005 | MECH |  |  |  |  |  |  |  | 12-027F | 12-054F |  |  |  |  |  | 242211410 |  |  |  |  |  | 13-015 | PR |  | PE | 13-002F |  |  |  |  |  |  |
| 242211410a | MECH GRP - Faraday cage protective enclosure system specifications and procurement prep - Labor FY14 |  | 57d | 2013-10-01 A | 2014-02-13 | 242211410 FS-64d | 50% | 64d | 2013-12-17 | 2014-03-18 | 299d | 0d | 8/5 M-F w/JLAB Holidays ReBaseline | MECH ENG [6.5 h] | 485.36 | 128.31 |  | 242.6775 | ELOUADRHIRI L | 1 | 1 | H | LATIFA E |  | Pat | 11-005 | MECH |  |  |  |  |  |  |  | 12-027F | 12-054F |  |  |  |  |  | 242211410 |  |  |  |  |  | 13-015 | PR |  | PE | 13-002F |  |  |  | 14-001 |  |  |
| 242211460 | MECH GRP - Cooling system: procurement - proc |  | 31d | 2013-10-01 A | 2013-11-15 | 9-140M FS+3d | 5% | 11d | 2013-11-01 | 2013-12-17 | 255d | 55d | 8/5 M-F w/JLAB Holidays ReBaseline | PROCUREMENT<$50K 60 | 8,158.2 |  |  | 380.98794 | ELOUADRHIRI L | 1 | 1 | D | LATIFA E |  | Pat | 11-005 | MECH | 11-058 | 12-013 |  | 7777.21206 | 380.98794 | 38098.794 | 100 |  | 12-054F |  |  |  |  |  | 242211460 |  |  |  |  |  | 13-015 | PR |  |  | 13-002F | CP | OB-2 |  | 14-001 |  |  |
| 242211635 | HBI - LV cards - Proc |  | 118d | 2013-10-01 A | 2014-03-31 | 9-140M FS+23d |  | 96d | 2013-11-01 | 2014-04-30 | 357d | 157d | 8/5 M-F w/JLAB Holidays ReBaseline | PROCUREMENT<$50K 60 | 50,583.74 |  |  | 0 | ELOUADRHIRI L | 1 | 1 | D | LATIFA E |  | Pat | 11-005 | MECH | 11-058 |  |  | 50583.74 | 0 | 0 | 100 |  | 12-054 |  |  |  |  |  | 242211635 |  |  |  |  |  | 13-015 | PR |  |  | 13-002F | PE | OB-2 |  | 14-001 |  |  |
| 242211655 | HBI - VXS crate - Proc |  | 118d | 2013-10-01 A | 2014-03-31 | 9-140M FS+23d |  | 96d | 2013-11-01 | 2014-04-30 | 357d | 157d | 8/5 M-F w/JLAB Holidays ReBaseline | PROCUREMENT<$50K 60 | 11,347.8 |  |  | 0 | ELOUADRHIRI L | 1 | 1 | U | LATIFA E |  | Pat | 11-005 | MECH | 11-058 |  |  | 11347.8 | 0 | 0 | 100 |  | 12-054 |  |  |  |  |  | 242211655 |  |  |  |  |  | 13-015 | PR |  |  | 13-002F | PE | OB-2 |  | 14-001 |  |  |
| 242211685 | MECH GRP - Region 4 Support, cooling, coldplate, and alignment structure: manufacturing Drawings - Labor |  | 68d | 2013-10-01 A | 2014-01-31 | 9-140M FS+10d | 15% | 55d | 2013-11-01 | 2014-02-19 | 269d | 0d | 8/5 M-F w/JLAB Holidays ReBaseline | MECH ENG [80 h]; PLABOR; MECH TECH [40 h] | 18,961.39 | 2,319.58 |  | 2844.2085 | ELOUADRHIRI L | 1 | 1 | S | LATIFA E | ST | Pat | 11-005 | MECH | 11-058 |  |  |  |  |  |  |  | 12-054 |  |  |  |  |  | 242211685 |  |  |  |  | PE | 13-015 | PR |  | PE | 13-002F |  |  |  | 14-001 |  |  |
| 242211710 | MECH GRP - Tooling for assembly and repairs: procurement prep - Labor FY13 |  | 20d | 2013-10-01 A | 2013-12-19 | 242211705a, 242211705 | 50% | 33d | 2013-11-19 | 2013-12-18 | 214d | 0d | 8/5 M-F w/JLAB Holidays ReBaseline | PLABOR; MECH ENG [3.72 h] | 277.77 | 114.09 |  | 134.5896 | ELOUADRHIRI L | 1 | 1 | H | LATIFA E |  | Pat | 11-005 | MECH | 11-058 |  |  |  |  |  |  |  | 12-054 |  |  |  |  |  | 242211710 |  |  |  |  |  | 13-015 | PR |  | PE | 13-002F |  |  |  |  |  |  |
| 242211710a | MECH GRP - Tooling for assembly and repairs: procurement prep - Labor FY14 |  | 23.5d | 2013-10-01 A | 2013-12-19 | 242211710 FS-40d, 242211705a FS-31d | 50% | 32.5d | 2013-12-19 | 2014-02-03 | 214.5d | 0.5d | 8/5 M-F w/JLAB Holidays ReBaseline | PLABOR; MECH ENG [4.28 h] | 319.59 | 132.44 |  | 159.7938 | ELOUADRHIRI L | 1 | 1 | H | LATIFA E |  | Pat | 11-005 | MECH | 11-058 |  |  |  |  |  |  |  | 12-054 |  |  |  |  |  | 242211710 |  |  |  |  |  | 13-015 | PR |  | PE | 13-002F |  |  |  | 14-001 |  |  |
| 242211445 | HBI - DAq-VSCM develop program and test - Labor |  | 98d | 2013-10-15 A | 2014-03-18 | 9-140M FS+12d | 8% | 87d | 2013-11-01 | 2014-04-02 | 249d | 49d | 8/5 M-F w/JLAB Holidays ReBaseline | ELEC ENG [240 h] | 18,031.2 | 2,344.06 |  | 1442.496 | ELOUADRHIRI L | 1 | 1 | S | LATIFA E | ST | Pat | 11-005 | HBI | 11-058 | 12-013 |  |  |  |  |  |  |  |  |  |  |  |  | 242211445 |  |  |  |  |  | 13-015 | PR |  | PE | 13-002F |  |  |  | 14-001 |  |  |
| 242211715 | MECH GRP - Tooling for assembly and repairs - Proc |  | 62d | 2013-11-01 | 2014-02-11 | 242211710 FS-33d, 242211710a FS-33d |  |  |  |  | 214d | 0d | 8/5 M-F w/JLAB Holidays ReBaseline | SUPPLIES & MATERIALS; PROCUREMENT<$50K 60 NO ESCALATION FY14 | 8,308.5 |  |  | 0 | ELOUADRHIRI L | 1 | 1 | D | LATIFA E |  | Pat | 11-005 | MECH | 11-058 |  |  | 8308.5 | 0 | 0 | 100 |  | 12-054 |  |  |  |  |  | 242211715 |  |  |  |  |  | 13-015 | PR |  |  | 13-002F | EJ |  |  |  |  |  |
| 242211725 | MECH GRP - Tooling for dissassembly, and repairs : manufacturing Drawings - Labor |  | 75d | 2013-11-01 | 2014-02-28 | 9-140M FS+23d |  |  |  |  | 355d | 0d | 8/5 M-F w/JLAB Holidays ReBaseline | PLABOR; MECH ENG [80 h] | 18,917.75 |  |  | 0 | ELOUADRHIRI L | 1 | 1 | S | LATIFA E | ST | Pat | 11-005 | MECH | 11-058 |  |  |  |  |  |  |  | 12-054 |  |  |  |  |  | 242211725 |  |  |  |  | PE | 13-015 | PR |  | PE | 13-002F |  |  |  | 14-001 |  |  |
| 242211475 | MECH GRP - Support, cooling, coldplate, and alignment of stave - Proc |  | 45d | 2013-11-15 | 2014-01-31 | 242211470 FS+18d |  |  |  |  | 200d | 0d | 8/5 M-F w/JLAB Holidays ReBaseline | PROCUREMENT<$50K 60 | 26,128.74 |  |  | 0 | ELOUADRHIRI L | 1 | 1 | D | LATIFA E |  | Pat | 11-005 | MECH | 11-058 | 12-013 |  | 26128.74 | 0 | 0 | 100 |  | 12-054 |  |  |  |  |  | 242211475 |  |  |  |  |  | 13-015 | PR |  |  | 13-002F | EJ |  |  | 14-001 |  |  |
| 242211876 | MECH GRP - Module shipping Charges from FNAL to Jlab - Proc |  | 216d | 2013-12-02 | 2014-10-15 | 242211875a FS-170d, 242211875 FS-170d, 9-140M FS+42d |  |  |  |  | 233d | 4d | 8/5 M-F w/JLAB Holidays ReBaseline | PROCUREMENT<$50K 60 NO ESCALATION FY15 | 13,414.7 |  |  | 0 | ELOUADRHIRI L | 1 | 1 | D | LATIFA E |  | Pat | 11-005 | MECH |  |  |  | 13414.7 | 0 | 0 | 100 |  |  |  |  |  |  |  | 242211876 |  |  |  |  |  | 13-015 | PR |  |  | 13-002F | EV |  |  | 14-001 |  |  |
| 242211520 | HBI - Electronics: HFCB Population - Proc Part B |  | 161d | 2013-12-04 | 2014-07-31 | 242211360 FS-75d |  |  |  |  | 305d | 0d | 8/5 M-F w/JLAB Holidays ReBaseline | PROCUREMENT<$50K 60 | 34,620.04 |  |  | 0 | ELOUADRHIRI L | 1 | 1 | U | LATIFA E |  | Pat | 11-005 | HBI | 11-058 | 12-013 |  | 34620.04 | 0 | 0 | 100 |  | 12-054F |  |  |  |  |  | 242211515 |  |  |  |  |  | 13-015 | PR |  |  | 13-002F | VQ |  |  | 14-001 |  |  |
| 242211645 | HBI - Module Reception tests at JLAB - Labor |  | 223d | 2013-12-09 | 2014-10-31 | 242211490 FS-200d, 242211490a FS-200d |  |  |  |  | 269d | 69d | 8/5 M-F w/JLAB Holidays ReBaseline | ELEC TECH [400 h]; ELEC ENG [200 h] | 33,822 |  |  | 0 | ELOUADRHIRI L | 1 | 1 | U | LATIFA E |  | Pat | 11-005 | MECH | 11-058 |  |  |  |  |  |  |  | 12-054 |  |  |  |  |  | 242211645 |  |  |  |  |  | 13-015 | PR |  | PE | 13-002F |  |  |  | 14-001 |  |  |
| 242211400a | HBI - Sloco:Slow controls for monitor and charge calib system: develop sloco software (1/2) - Labor |  | 109d | 2014-01-03 | 2014-06-06 | 9-140M FS+60d |  |  |  |  | 309d | 109d | 8/5 M-F w/JLAB Holidays ReBaseline | ELEC ENG [160 h]; ELEC TECH [360 h] | 28,937.2 |  |  | 0 | ELOUADRHIRI L | 1 | 1 | S | LATIFA E | ST | Pat | 11-005 | HBI | 11-058 |  |  |  |  |  |  | 12-027 | 12-054F | 12-053 |  |  |  |  | 242211400a |  |  |  |  |  | 13-015 | PR |  | PE | 13-002F |  |  |  | 14-001 |  |  |
| 242211890 | MECH GRP - Module inserts Copper/PEEK Part B |  | 54d | 2014-01-03 | 2014-03-20 | 9-140M FS+60d |  |  |  |  | 615d | 286d | 8/5 M-F w/JLAB Holidays ReBaseline | PROCUREMENT<$50K 60 | 42,735.11 |  |  | 0 | ELOUADRHIRI L | 1 | 1 | D | LATIFA E |  | Pat | 11-005 | MECH |  |  |  | 42735.11 | 0 | 0 | 100 |  |  |  |  |  |  |  | 242211885 |  |  |  |  |  | 13-015 | PR |  |  | 13-002F | PE |  |  | 14-001 |  |  |
| 242211825 | Installation MECH GRP - AC Distribution - proc prep - Labor |  | 10d | 2014-01-07 | 2014-01-21 | 9-140M FS+62d |  |  |  |  | 436d | 0d | 8/5 M-F w/JLAB Holidays ReBaseline | MECH TECH; ELEC TECH [40 h] | 1,879.6 |  |  | 0 | ELOUADRHIRI L | 1 | 1 | H | LATIFA E |  | Pat | 11-005 | MECH | 11-058 |  |  |  |  |  |  |  | 12-054 |  |  |  |  |  | 242211825 |  |  |  |  |  | 13-015 | PR |  | PE | 13-002F |  |  |  | 14-001 |  |  |
| 242211830 | Installation MECH GRP - AC Distribution - Proc |  | 21d | 2014-01-22 | 2014-02-19 | 242211825 |  |  |  |  | 436d | 236d | 8/5 M-F w/JLAB Holidays ReBaseline | PROCUREMENT<$50K 60 | 8,076.07 |  |  | 0 | ELOUADRHIRI L | 1 | 1 | D | LATIFA E |  | Pat | 11-005 | MECH | 11-058 |  |  | 8076.07 | 0 | 0 | 100 |  | 12-054 |  |  |  |  |  | 242211830 |  |  |  |  |  | 13-015 | PR |  |  | 13-002F | PE |  |  | 14-001 |  |  |
| 242211800 | Installation MECH GRP - Support and alignment tube, MFG Drawings - Labor |  | 42d | 2014-01-30 | 2014-03-28 | 9-140M FS+78d |  |  |  |  | 296d | 0d | 8/5 M-F w/JLAB Holidays ReBaseline | PLABOR; MECH ENG [80 h] | 13,370.26 |  |  | 0 | ELOUADRHIRI L | 1 | 1 | S | LATIFA E | ST | Pat | 11-005 | MECH | 11-058 |  |  |  |  |  |  |  | 12-054 |  |  |  |  |  | 242211800 |  |  |  |  | PE | 13-015 | PR |  | PE | 13-002F |  |  |  | 14-001 |  |  |
| 242211480 | MECH GRP - Support, cooling, coldplate, and alignment of stave Faraday Cage inner: construct and assemble - Labor |  | 11d | 2014-02-03 | 2014-02-17 | 242211340, 242211415 FS-120d, 242211475 |  |  |  |  | 200d | 0d | 8/5 M-F w/JLAB Holidays ReBaseline | PLABOR; MECH ENG [40 h]; MECH TECH [240 h] | 16,192.76 |  |  | 0 | ELOUADRHIRI L | 1 | 1 | S | LATIFA E | ST | Pat | 11-005 | MECH | 11-058 | 12-013 |  |  |  |  |  |  | 12-054 |  |  |  |  |  | 242211480 |  |  |  |  | PE | 13-015 | PR |  | PE | 13-002F |  |  |  | 14-001 |  |  |

Notes:
- 142211445: Steps: BST R1-R3 HBI - 9 DAq-SCM (3) develop program and test (2/2) - Labor (done)
- 242211360: Explanation: HFCB boards (63 @ $625) $39,375, setup $1400, electrical test / $650, connector head (126 @ $3.2578) $410.48, SMT conn. 37 pin (63 @ / $122.10) $7962.30, SMT conn. 51 pin (63 @ $180.54) $11,374.02, / additional board parts (63 @ $21.67) $1365.21
- 242211361: Explanation: HFCB boards (63 @ $625) $39,375, setup $1400, electrical test / $650, connector head (126 @ $3.2578) $410.48, SMT conn. 37 pin (63 @ / $122.10) $7962.30, SMT conn. 51 pin (63 @ $180.54) $11,374.02, / additional board parts (63 @ $21.67) $1365.21
- 242211365a: Explanation: cable (1000') $2821.55, cable (1000') $795.73, connectors / (1400 @ 0.0773) $108.26, connectors single row (212 @ 0.526) $111.51, straight / plug conncetor 37 pin (106 @ 124.13) $13,157.78, straight plug / conncetor 51 pin (106 @ 181.36) $19224.16
- 242211367: Explanation: cable (1000') $2821.55, cable (1000') $795.73, connectors / (1400 @ 0.0773) $108.26, connectors single row (212 @ 0.526) $111.51, straight / plug conncetor 37 pin (106 @ 124.13) $13,157.78, straight plug / conncetor 51 pin (106 @ 181.36) $19224.16
- 242211370: Steps: Manufacture Region 1 HV cables; Test Region 1 HV cables; Manufacture Region 2 HV cables; Test Region 2 HV cables; Manufacture Region 3 HV cables; Test Region 3 HV cables; Manufacture Region 4 HV cables; Test Region 4 HV cables; Manufacture Spare HV cables; Test spare HV cables; Manufacture Region 1 LV cables (done); Test Region 1 LV cables (done); Manufacture Region 2 LV cables (done); Test Region 2 LV cables (done); Manufacture Region 3 LV cables; Test Region 3 LV cables; Manufacture Region 4 LV cables; Test Region 4 LV cables; Manufacture spare L V cables; Test spare LV cables; Manufacture Region 1 Slow Controls cables; Test Region 1 Slow Controls cables; Manufacture Region 2 Slow Controls cables; Test Region 2 Slow Controls cables; Manufacture Region 3 Slow Controls cables; Test Region 3 Slow Controls cables; Manufacture Region 4 Slow Controls cables; Test Region 4 Slow Controls cables; Manufacture spare Slow Controls cables; Test spare Slow Controls cables; Test pulser cables; Test data cables
- 242211370a: Steps: Manufacture Region 1 HV cables; Test Region 1 HV cables; Manufacture Region 2 HV cables; Test Region 2 HV cables; Manufacture Region 3 HV cables; Test Region 3 HV cables; Manufacture Region 4 HV cables; Test Region 4 HV cables; Manufacture Spare HV cables; Test spare HV cables; Manufacture Region 1 LV cables (done); Test Region 1 LV cables (done); Manufacture Region 2 LV cables (done); Test Region 2 LV cables (done); Manufacture Region 3 LV cables; Test Region 3 LV cables; Manufacture Region 4 LV cables; Test Region 4 LV cables; Manufacture spare L V cables; Test spare LV cables; Manufacture Region 1 Slow Controls cables; Test Region 1 Slow Controls cables; Manufacture Region 2 Slow Controls cables; Test Region 2 Slow Controls cables; Manufacture Region 3 Slow Controls cables; Test Region 3 Slow Controls cables; Manufacture Region 4 Slow Controls cables; Test Region 4 Slow Controls cables; Manufacture spare Slow Controls cables; Test spare Slow Controls cables; Test pulser cables; Test data cables
- 242211465: Steps: MECH GRP - Support, cooling, coldplate, and alignment of stave: manufacturing Drawings - Labor (done)
- 242211515: Explanation: total PCB assembly
- 242211530: Explanation: total PCB assembly
- 242211390: Explanation: analog module $511.97, input module $511.97, 8-slot / backplane $608.75, LabVIEW real-time/Ethernet controller $1837.85, NI standard / system assurance program $250, PS-4 power supply $240.98, connector block (2 @ / 163.56) $327.12, LabVIEW real-time module $2515.31, optical module / $24,765
- 242211405: Steps: Completion of CAD model Part A; Completion of CAD model Part b (done); Completion of drawings; Drawings review and release
- 242211685: Steps: Completion of CAD model Part A (done); Completion of CAD model Part B; Completion of drawings; Drawings review and release
- 242211445: Steps: Test multiple VSCM cards in VXS crates (done); Test clock distribution via SD cards; Test TI cards with multiple crates; Test With Region 1 Modules; Test SVT TI with CLAS12 master trigger; Test Data Rates / Event Builder FIFO; Test with System Crates R1, R2, R3, & R4; Test Triggering Rates / Efficiency; Test Block Transfers / Max Rates; Test Full System Crates R1 - R4; Test SVT TI with CLAS12 L1 trigger; Integrate with CODA
- 242211725: Steps: Completion of CAD model Part A; Completion of CAD model Part B; Completion of drawings; Drawings review and release
- 242211520: Explanation: total PCB assembly
- 242211400a: Steps: Write EPICS Device Driver for Isolated ADC modules; Develop User Interfaces (GUI); Write support for Chiller asyn driver Interface; Develop EPICS record Database; Determine Alarm levels and responses; Write Alarm Handler; Develop SVT Channel Archiver; Write SVT Strip Tool plotting Interface; Develop Sequencer Applications; Develop BURT (Backup and Restore Tool) for SVT EPICS Slow Controls; Develop SVT Archiver interface & Histogramming; Test and debug Interlock levels; Test and debug complete SVT EPICS System; Integrate & Test SVT Slow Controls System into CLAS12 Systems
- 242211800: Steps: Completion of CAD model; Completion of drawings; Drawings review and release
- 242211480: Steps: Inspection of parts; Assembly of parts

| ID | Activity | Type | Duration | Start | Finish | Predecessors | Total float | Free float | Calendar | Resources | Cost | Original Activity ID Rebaseline | MONTHLY EV COST | RESP - Responsibility | STRT%COMP for CM EVM | FNSH%COMP for CM EVM | EVMS Reporting Codes | CAM RESPONSIBLE | Pat's Code | CR 11-005 | SVT | CR 11-058 | CR 12-054 | CR 13-002 | BOE Labor | CR 13-015 | Post Rebaseline | CR 14-001 | Remaining Material Cost Based on % Compl | Claimed Material Cost Based on % Complet | Initial Claimed Material Calc | Claimed Material Divider | BOE Procurement | Activities with Steps | CR 12-027 | CR 12-053 | BOE Expenses | CR 12-013 | LOE % Pre Calc | LOE % | LOE Divider | LOE Multiplier | CR 12-001 |
| --- | --- | --- | --- | --- | --- | --- | --- | --- | --- | --- | --- | --- | --- | --- | --- | --- | --- | --- | --- | --- | --- | --- | --- | --- | --- | --- | --- | --- | --- | --- | --- | --- | --- | --- | --- | --- | --- | --- | --- | --- | --- | --- | --- |
| 242211690 | MECH GRP - Region 4 Support, cooling, coldplate, and alignment structure: procurement prep - Labor |  | 10d | 2014-02-03 | 2014-02-14 | 9-140M FS+10d, 242211685 | 269d | 0d | 8/5 M-F w/JLAB Holidays ReBaseline | MECH ENG [8 h] | 597.36 | 242211690 | 0 | ELOUADRHIRI L | 1 | 1 | H | LATIFA E | Pat | 11-005 | MECH | 11-058 | 12-054 | 13-002F | PE | 13-015 | PR | 14-001 |  |  |  |  |  |  |  |  |  |  |  |  |  |  |  |
| 242211745 | MECH GRP - Environmental Control System - Proc |  | 161d | 2014-02-03 | 2014-09-18 | 9-140M FS+80d | 237d | 37d | 8/5 M-F w/JLAB Holidays ReBaseline | PROCUREMENT<$50K 60 | 24,794.12 | 242211745 | 0 | ELOUADRHIRI L | 1 | 1 | D | LATIFA E | Pat | 11-005 | MECH | 11-058 | 12-054 | 13-002F |  | 13-015 | PR | 14-001 | 24794.12 | 0 | 0 | 100 | CP |  |  |  |  |  |  |  |  |  |  |
| 242211395 | HBI - Sloco:Slow controls for monitoring and charge calib system: assemble, test, and debug ADC's- Labor |  | 42d | 2014-02-05 | 2014-04-03 | 242211390 | 354d | 154d | 8/5 M-F w/JLAB Holidays ReBaseline | ELEC ENG [160 h]; ELEC TECH [160 h] | 19,539.2 | 242211395 | 0 | ELOUADRHIRI L | 1 | 1 | S | LATIFA E | Pat | 11-005 | HBI | 11-058 | 12-054 | 13-002F | PE | 13-015 | PR | 14-001 |  |  |  |  |  | ST | 12-027 | 12-053 |  |  |  |  |  |  |  |
| 242211720 | MECH GRP - Tooling for assembly and repairs construct and assemble - Labor |  | 15d | 2014-02-12 | 2014-03-04 | 242211715 | 214d | 14d | 8/5 M-F w/JLAB Holidays ReBaseline | PLABOR; MECH ENG [40 h]; MECH TECH [160 h] | 14,256.33 | 242211720 | 0 | ELOUADRHIRI L | 1 | 1 | S | LATIFA E | Pat | 11-005 | MECH | 11-058 | 12-054 | 13-002F | PE | 13-015 | PR | 14-001 |  |  |  |  |  | ST |  |  | PE |  |  |  |  |  |  |
| 242211415 | MECH GRP - Faraday cage protective enclosure system - Proc |  | 12d | 2014-02-14 | 2014-03-03 | 242211410a, 242211410 | 299d | 99d | 8/5 M-F w/JLAB Holidays ReBaseline | PROCUREMENT<$50K 60 | 12,973.05 | 242211415 | 0 | ELOUADRHIRI L | 1 | 1 | D | LATIFA E | Pat | 11-005 | MECH |  | 12-054 | 13-002F |  | 13-015 | PR | 14-001 | 12973.05 | 0 | 0 | 100 | EJ |  | 12-027 |  |  |  |  |  |  |  |  |
| 242211695 | MECH GRP - Region 4 Support, cooling, coldplate, and alignment structure: - Proc |  | 31d | 2014-02-17 | 2014-03-31 | 242211690 | 269d | 0d | 8/5 M-F w/JLAB Holidays ReBaseline | PROCUREMENT<$50K 60 | 18,378.14 | 242211695 | 0 | ELOUADRHIRI L | 1 | 1 | D | LATIFA E | Pat | 11-005 | MECH | 11-058 | 12-054 | 13-002F |  | 13-015 | PR | 14-001 | 18378.14 | 0 | 0 | 100 | EJ |  |  |  |  |  |  |  |  |  |  |
| 242211485 | MECH GRP - Mounting and aligning on support structure in lab, R1-R3 - Labor |  | 118d | 2014-02-18 | 2014-08-04 | 242211380, 242211645 FS-250d, 242211720 FS-25d, 242211415 FS-140d, 242211460, 242211480 | 200d | 0d | 8/5 M-F w/JLAB Holidays ReBaseline | PLABOR; MECH ENG [40 h]; MECH TECH [480 h] | 27,549.56 | 242211485 | 0 | ELOUADRHIRI L | 1 | 1 | S | LATIFA E | Pat | 11-005 | MECH | 11-058 | 12-054 | 13-002F | PE | 13-015 | PR | 14-001 |  |  |  |  |  | ST |  |  | PE |  |  |  |  |  |  |
| 242211615 | HBI - Full system R1-R3, test and burn-in in Cleanroom EEL 121 - Labor |  | 115d | 2014-02-28 | 2014-08-11 | 242211485 FS-110d, 242211365a FS-103.75d, 242211370 FS-114d, 242211445 FS-62d, 242211367 FS-103.75d, 242211370a FS-114d | 200d | 0d | 8/5 M-F w/JLAB Holidays ReBaseline | ELEC TECH [180 h]; ELEC ENG [180 h]; VISTNG USERS [1280 h] | 48,336.8 | 242211615 | 0 | ELOUADRHIRI L | 1 | 1 | S | LATIFA E | Pat | 11-005 | MECH | 11-058 | 12-054 | 13-002F | PE | 13-015 | PR | 14-001 |  |  |  |  |  | ST |  |  |  |  |  |  |  |  |  |
| 242211730 | MECH GRP - Tooling for disassembly and repairs: procurement prep - Labor |  | 10d | 2014-03-03 | 2014-03-14 | 242211725 | 355d | 0d | 8/5 M-F w/JLAB Holidays ReBaseline | PLABOR; MECH ENG [16 h] | 1,194.72 | 242211730 | 0 | ELOUADRHIRI L | 1 | 1 | H | LATIFA E | Pat | 11-005 | MECH | 11-058 | 12-054 | 13-002F | PE | 13-015 | PR | 14-001 |  |  |  |  |  |  |  |  |  |  |  |  |  |  |  |
| 242211875a | MECH GRP - Construct silicon module shipping containers -Proc Part B |  | 98d | 2014-03-04 | 2014-07-21 | 9-140M FS+100d | 248d | 15d | 8/5 M-F w/JLAB Holidays ReBaseline | PROCUREMENT<$50K 60 | 30,981.77 | 242211875 | 0 | ELOUADRHIRI L | 1 | 1 | D | LATIFA E | Pat | 11-005 | MECH |  |  | 13-002F |  | 13-015 | PR | 14-001 | 30981.77 | 0 | 0 | 100 | PE |  |  |  |  |  |  |  |  |  |  |
| 242211735 | MECH GRP - Tooling for disassembly, and repairs - Proc |  | 54d | 2014-03-17 | 2014-05-30 | 242211730 | 355d | 0d | 8/5 M-F w/JLAB Holidays ReBaseline | SUPPLIES & MATERIALS; PROCUREMENT<$50K 60 | 12,104.19 | 242211735 | 0 | ELOUADRHIRI L | 1 | 1 | D | LATIFA E | Pat | 11-005 | MECH | 11-058 | 12-054 | 13-002F |  | 13-015 | PR | 14-001 | 12104.19 | 0 | 0 | 100 | EJ |  |  |  |  |  |  |  |  |  |  |
| 242211805 | Installation MECH GRP - Support & alignment tube - Proc - prep - Labor |  | 10d | 2014-03-31 | 2014-04-11 | 242211800 | 296d | 0d | 8/5 M-F w/JLAB Holidays ReBaseline | MECH TECH [40 h] | 1,892.8 | 242211805 | 0 | ELOUADRHIRI L | 1 | 1 | H | LATIFA E | Pat | 11-005 | MECH | 11-058 | 12-054 | 13-002F | PE | 13-015 | PR | 14-001 |  |  |  |  |  |  |  |  |  |  |  |  |  |  |  |
| 242211660 | INFRA STR - Backup Environmental and power system for SVT Clean Room - Proc |  | 43d | 2014-04-01 | 2014-05-30 | 9-140M FS+120d | 314d | 114d | 8/5 M-F w/JLAB Holidays ReBaseline | PROCUREMENT<$50K 60 | 6,448.34 | 242211660 | 0 | ELOUADRHIRI L | 1 | 1 | D | LATIFA E | Pat | 11-005 | MECH | 11-058 | 12-054 | 13-002F |  | 13-015 | PR | 14-001 | 6448.34 | 0 | 0 | 100 | EJ |  |  |  |  |  |  |  |  |  |  |
| 242211675 | INFRA STR - Integrated Humidity Reduction System for SVT Control room - Proc |  | 43d | 2014-04-01 | 2014-05-30 | 9-140M FS+120d | 314d | 114d | 8/5 M-F w/JLAB Holidays ReBaseline | PROCUREMENT<$50K 60 | 8,776.54 | 242211670 | 0 | ELOUADRHIRI L | 1 | 1 | D | LATIFA E | Pat | 11-005 | MECH | 11-058 | 12-054 | 13-002F |  | 13-015 | PR | 14-001 | 8776.54 | 0 | 0 | 100 | PE |  |  |  |  |  |  |  |  |  |  |
| 242211700 | MECH GRP - Region 4 Support, cooling, coldplate, and alignment structure: construct & assemble - Labor |  | 14d | 2014-04-01 | 2014-04-18 | 242211695 | 269d | 69d | 8/5 M-F w/JLAB Holidays ReBaseline | PLABOR; MECH ENG [40 h]; MECH TECH [160 h] | 12,407.16 | 242211700 | 0 | ELOUADRHIRI L | 1 | 1 | S | LATIFA E | Pat | 11-005 | MECH | 11-058 | 12-054 | 13-002F | PE | 13-015 | PR | 14-001 |  |  |  |  |  | ST |  |  | PE |  |  |  |  |  |  |
| 242211810 | Installation MECH GRP - Support and alignment tube - Proc |  | 33d | 2014-04-14 | 2014-05-29 | 242211805 | 296d | 0d | 8/5 M-F w/JLAB Holidays ReBaseline | PROCUREMENT<$50K 60 | 16,481.78 | 242211810 | 0 | ELOUADRHIRI L | 1 | 1 | D | LATIFA E | Pat | 11-005 | MECH | 11-058 | 12-054 | 13-002F |  | 13-015 | PR | 14-001 | 16481.78 | 0 | 0 | 100 | EJ |  |  |  |  |  |  |  |  |  |  |
| 242211160w5 | FNAL Construction and test (Jlab/FNAL) of R4 production modules Phase 2 |  | 112d | 2014-04-23 | 2014-09-30 | 242211520 FS-70d, 242211515 FS-325d, 242211160u FS-182d | 305d | 76d | 8/5 M-F w/JLAB Holidays ReBaseline | PROCUREMENT>$50K 69 NO ESCALATION FY14 | 63,581.94 | 242211160w | 0 | ELOUADRHIRI L | 1 | 1 | D | LATIFA E | Pat | 11-005 |  | 11-058 |  | 13-002F |  | 13-015 | PR |  | 63581.94 | 0 | 0 | 100 | OB |  |  |  |  | 12-013 |  |  |  |  |  |
| 242211740 | MECH GRP - Tooling for disassembly and repairs Build - Labor |  | 30d | 2014-05-02 | 2014-06-13 | 242211735 FS-20d | 355d | 155d | 8/5 M-F w/JLAB Holidays ReBaseline | PLABOR; MECH ENG [40 h]; MECH TECH [160 h] | 14,256.33 | 242211740 | 0 | ELOUADRHIRI L | 1 | 1 | S | LATIFA E | Pat | 11-005 | MECH | 11-058 | 12-054 | 13-002F | PE | 13-015 | PR | 14-001 |  |  |  |  |  | ST |  |  | PE |  |  |  |  |  |  |
| 242211860 | Installation MECH GRP - Purging system: procurement prep - Labor |  | 10d | 2014-05-13 | 2014-05-27 | 9-140M FS+150d | 276d | 0d | 8/5 M-F w/JLAB Holidays ReBaseline | MECH ENG [40 h] | 2,986.8 | 242211860 | 0 | ELOUADRHIRI L | 1 | 1 | H | LATIFA E | Pat | 11-005 | MECH |  |  | 13-002F | PE | 13-015 | PR | 14-001 |  |  |  |  |  |  |  |  |  |  |  |  |  |  |  |
| 242211865 | Installation MECH GRP - Purging system: installation - Proc |  | 21d | 2014-05-28 | 2014-06-25 | 242211860 | 276d | 76d | 8/5 M-F w/JLAB Holidays ReBaseline | PROCUREMENT<$50K 60 | 5,493.93 | 242211865 | 0 | ELOUADRHIRI L | 1 | 1 | D | LATIFA E | Pat | 11-005 | MECH |  |  | 13-002F |  | 13-015 | PR | 14-001 | 5493.93 | 0 | 0 | 100 | EJ |  |  |  |  |  |  |  |  |  |  |
| 242211815 | Installation MECH GRP - Support and alignment (construction) - Labor |  | 19d | 2014-05-30 | 2014-06-25 | 242211810 | 296d | 96d | 8/5 M-F w/JLAB Holidays ReBaseline | MECH ENG [40 h]; MECH TECH [80 h] | 6,772.4 | 242211815 | 0 | ELOUADRHIRI L | 1 | 1 | H | LATIFA E | Pat | 11-005 | MECH | 11-058 | 12-054 | 13-002F | PE | 13-015 | PR | 14-001 |  |  |  |  |  |  |  |  |  |  |  |  |  |  |  |
| 242211545 | MECH GRP - Mounting and aligning on support structure in lab, R4 - Labor |  | 54d | 2014-07-29 | 2014-10-13 | 242211700, 242211615 FS-10d | 200d | 0d | 8/5 M-F w/JLAB Holidays ReBaseline | PLABOR; MECH TECH [240 h]; MECH ENG [40 h] | 16,192.76 | 242211545 | 0 | ELOUADRHIRI L | 1 | 1 | S | LATIFA E | Pat | 11-005 | MECH | 11-058 | 12-054 | 13-002F | PE | 13-015 | PR | 14-001 |  |  |  |  |  | ST |  |  | PE |  |  |  |  |  |  |
| 242211600 | HBI - Full system R4, test and burn-in in Cleanroom EEL 121 - Labor |  | 20d | 2014-09-30 | 2014-10-27 | 242211545 FS-10d, 242211367 | 210d | 10d | 8/5 M-F w/JLAB Holidays ReBaseline | ELEC ENG [160 h]; ELEC TECH [160 h]; VISTNG USERS [320 h] | 26,128 | 242211600 | 0 | ELOUADRHIRI L | 1 | 1 | S | LATIFA E | Pat | 11-005 | MECH | 11-058 | 12-054 | 13-002F | PE | 13-015 | PR | 14-001 |  |  |  |  |  | ST |  |  |  |  |  |  |  |  |  |
| 242211495M | End of BST R1-R4 Production | milestone | 0d | 2014-09-30 | 2014-09-30 | 242211876 FS-15d, 242211490, 242211490a | 229d | 29d | 8/5 M-F w/JLAB Holidays ReBaseline |  |  | 242211495M | 0 | ELOUADRHIRI L | 1 | 1 | M | LATIFA E | Pat | 11-005 | MECH | 11-058 | 12-054 | 13-002F |  | 13-015 | PR |  |  |  |  |  |  |  |  |  |  |  |  |  |  |  |  |
| 242211145 | HBI - SVT Engineering and Construction Oversight FY15 |  | 23d | 2014-10-01 | 2014-10-31 | 242211140, 242211014E | 719d | 557d | 8/5 M-F w/JLAB Holidays ReBaseline | SCIENTIST [160 h] | 12,028.8 | 242211145 | 0 | ELOUADRHIRI L | 1 | 1 | E | LATIFA E | Pat | 11-005 | HBI |  |  |  | PE | 13-015 | PR | 14-001 |  |  |  |  |  |  |  |  |  |  | 100 | 0 | 100 | 100 | 12-001 |
| 242211870 | Installation MECH GRP - Purging system: installation in clean room- Labor |  | 20d | 2014-10-14 | 2014-11-10 | 242211545, 242211865 | 200d | 0d | 8/5 M-F w/JLAB Holidays ReBaseline | PLABOR; MECH ENG [40 h]; MECH TECH [80 h] | 6,772.4 | 242211870 | 0 | ELOUADRHIRI L | 1 | 1 | H | LATIFA E | Pat | 11-005 | MECH |  |  | 13-002F | PE | 13-015 | PR | 14-001 |  |  |  |  |  |  |  |  |  |  |  |  |  |  |  |
| 242211680 | MECH GRP - Full system test Integration of SVT R3/R4 - Labor |  | 51d | 2014-11-11 | 2015-02-04 | 242211600, 242211400a, 242211635, 242211675, 242211655, 242211670, 242211395, 242211495M, 242211660, 242211745, 242211870, 242211815 | 200d | 0d | 8/5 M-F w/JLAB Holidays ReBaseline | ELEC ENG [148 h]; ELEC TECH [148 h]; MECH ENG [72 h]; MECH TECH [220 h]; VISTNG USERS [240 h] | 38,802 | 242211680 | 0 | ELOUADRHIRI L | 1 | 1 | S | LATIFA E | Pat | 11-005 | MECH | 11-058 | 12-054 | 13-002F | PE | 13-015 | PR | 14-001 |  |  |  |  |  | ST |  |  |  |  |  |  |  |  |  |
| 242211918M | SVT Ready for Installation | milestone | 0d | 2015-02-04 | 2015-02-04 | 242211830, 242211145 FS-500d, 242211755, 242211361, 242211680, 242211530, 242211740 | 200d | 0d | 8/5 M-F w/JLAB Holidays ReBaseline |  |  | 242211918M | 0 | ELOUADRHIRI L | 1 | 1 | M | LATIFA E | Pat | 11-005 |  | 11-058 | 12-054 | 13-002F |  | 13-015 | PR |  |  |  |  |  |  |  |  |  |  |  |  |  |  |  |  |

Notes:
- 242211395: Steps: Test sensors (temperature & humidity); Assemble tested sensors in the silicon detector barrel; Assemble & Test Slow Controls patch panel and breakout blocks; Connect & test HFCB, RTD's, and Humidity sensors to terminal Blocks; Install and Test Isolated ADC's / RTD VME Modules; Install and Test Relay and DAC VME Modules; Test Chiller / flow sensor slow controls; Test ground isolation on HFCB Grounds to Isolated ADC's; Test and calibrate individual monitoring sensors; Debug complete SVT Slow Controls System Hardware
- 242211720: Steps: Check parts for transition fixture; Assemble transition fixture; Check parts for transition cart; Assemble transition cart
- 242211485: Steps: Region 1 Assembly set up and survey; Insert inner shell; Assemble Region 1 Part A (5 modules); Assemble Region 1 Part B (5 modules); Region 2 assembly set up and survey; Assemble Region 2 Part A (5 modules); Assemble Region 2 Part B (5 modules); Assemble Region 2 Part C (4 modules); Region 3 assembly set up and survey; Assemble Region 3 Part A (6 modules); Assemble Region 3 Part B (6 modules); Assemble Region 3 Part C (6 modules); Install Faraday cage components
- 242211615: Steps: Checkout of safety system (interlock LV/HV/cooling/gas before starting R1; Checkout of the High-Voltage system and distribution R1; Checkout of the Low-Voltage System R1; Checkout of Front-End electronics R1; Checkout of DAQ and Trigger R1; Checkout of safety system (interlock LV/HV/cooling/gas before starting R2; Checkout of the High-Voltage system and distribution R2; Checkout of the Low-Voltage System R2; Checkout of Front-End electronics R2; Checkout of DAQ and Trigger R2; Checkout of safety system (interlock LV/HV/cooling/gas before starting R1+R2; Checkout of the High-Voltage system and distribution R1+R2; Checkout of the Low-Voltage System R1+R2; Checkout of Front-End electronics R1+R2; Checkout of DAQ and Trigger R1+R2; Checkout of safety system (interlock LV/HV/cooling/gas before starting R3; Checkout of the High-Voltage system and distribution R3; Checkout of the Low-Voltage System R3; Checkout of Front-End electronics R3; Checkout of DAQ and Trigger R3; Checkout of safety system (interlock LV/HV/cooling/gas before starting R1+R2+R3; Checkout of the High-Voltage system and distribution R1+R2+R3; Checkout of the Low-Voltage System R1+R2+R3; Checkout of Front-End electronics R1+R2+R3; Checkout of DAQ and Trigger R1+R2+R3
- 242211700: Steps: Inspection of parts; Assembly of parts
- 242211740: Steps: Check parts; Assemble fixture
- 242211545: Steps: Region 4 Assembly set-up and survey; Insert R4 inner shell; Assemble Region 4 Part A (6 modules); Assemble Region 4 Part B (6 modules); Assemble Region 4 Part C (6 modules); Assemble Region 4 Part D (6 modules); Install Region 4 Faraday cage components
- 242211600: Steps: Checkout of safety system (interlock LV/HV/cooling/gas before starting R1+R2+R3; Checkout of the High-Voltage system and distribution R1+R2+R3; Checkout of the Low-Voltage System R1+R2+R3; Checkout of Front-End electronics R1+R2+R3; Checkout of DAQ and Trigger R1+R2+R3
- 242211680: Steps: Transport R3 and R4 to the large clean room.; Insert and attach R3 to R4; Hook all services (cooling lines, nitrogen gas lines, power supplies, and interlocks); Survey position of R3 with respect to R4; Install Faraday cage over R4
- 242211918M: Steps: (New step)

| ID | WBS | Activity | Type | Duration | Start | Finish | Predecessors | Complete | Planned start | Planned finish | Resources | Cost | Actual cost | LOE Divider | LOE Multiplier | Calculated Remaining Total Cost | MONTHLY EV COST | RESP - Responsibility | STRT%COMP for CM EVM | FNSH%COMP for CM EVM | CR 07-024 | EVMS Reporting Codes | CAM RESPONSIBLE | CR 08-058 | CR 10-015 | CR 11-026 | CR 11-035 | Milestone Level | CR 11-027 | Advance Purchase Plan > 500K | CR 09-026 | CR 08-046 | Remaining Material Cost Based on % Compl | Claimed Material Cost Based on % Complet | Initial Claimed Material Calc | Claimed Material Divider | Activities with Steps | CR 08-016 | CR 09-012 | CR 10-001 | CR 11-038 | CR 08-043 | CR 11-001 | CR 11-010 | CR 11-031 | LOE % Pre Calc | LOE % | CR 12-001 | Phil Dev | OPC Allison | CR 12-053 | CR 10-026 |
| --- | --- | --- | --- | --- | --- | --- | --- | --- | --- | --- | --- | --- | --- | --- | --- | --- | --- | --- | --- | --- | --- | --- | --- | --- | --- | --- | --- | --- | --- | --- | --- | --- | --- | --- | --- | --- | --- | --- | --- | --- | --- | --- | --- | --- | --- | --- | --- | --- | --- | --- | --- | --- |
|  | 2 | **1.4.2.2.1.2 CENTRAL TRACKER** |  |  |  |  |  |  |  |  |  |  |  |  |  |  |  |  |  |  |  |  |  |  |  |  |  |  |  |  |  |  |  |  |  |  |  |  |  |  |  |  |  |  |  |  |  |  |  |  |  |  |
|  | 3 | **1.4.2.2.1.3 FORWARD DRIFT CHAMBERS** |  |  | 2009-01-02 | 2015-04-01 |  |  |  |  |  |  |  |  |  |  |  |  |  |  |  |  |  |  |  |  |  |  |  |  |  |  |  |  |  |  |  |  |  |  |  |  |  |  |  |  |  |  |  |  |  |  |
| 142213009E |  | FY09 Travel (FWD Chambers) |  | 189d | 2009-01-02 A | 2009-09-30 A | 142213009EX | 100% |  |  | TRAVEL | 2,028.73 |  | 100 | 100 | 0 | 2028.73 | ELOUADRHIRI L | 1 | 1 | 07-024 | E | LATIFA E | 08-058 | 10-015 | 11-026 | 11 -035 |  |  |  |  |  |  |  |  |  |  |  |  |  |  |  |  |  |  |  |  |  |  |  |  |  |
| 142213000M |  | DC-P-#1 Constrction Start P-#1 (F DRFT CHAM) | milestone | 0d | 2009-04-01 A | 2009-04-01 A | 9-090M, 12222035M | 100% | 2009-05-01 | 2009-05-01 |  |  |  |  |  |  | 0 | ELOUADRHIRI L | 1 | 1 |  | M | LATIFA E |  | 10-015 | 11-026 | 11 -035 | 6 | 11-027 |  |  |  |  |  |  |  |  |  |  |  |  |  |  |  |  |  |  |  |  |  |  |  |
| 142213017 |  | P-#1 Proc Endplates & Frames LABOR Initial |  | 42d | 2009-05-01 A | 2009-06-30 A | 9-090M FS+60d, 142213000M | 100% |  |  | MECH DES [141.3 h]; MECH ENG [80.74 h]; MECH TECH [222.03 h]; SCIENTIST [60.55 h]; CONTRB UNIV LBR [121.11 h]; PD UNIV STAFF [565.17 h] | 53,121.45 | 53,121.45 |  |  | 0 | 53121.4617 | ELOUADRHIRI L | 1 | 1 |  | H | LATIFA E |  | 10-015 | 11-026 | 11 -035 |  |  | APP | 09-026 |  |  |  |  |  |  |  |  |  |  |  |  |  |  |  |  |  |  |  |  |  |
| 142213020 |  | P-#1 Proc Box Assy. & Fixtures LABOR |  | 200d | 2009-05-06 A | 2010-02-26 A | 9-090M FS+145d | 100% |  |  | MECH TECH [160 h] | 6,572.1 | 6,572.1 |  |  | 0 | 6472 | ELOUADRHIRI L | 1 | 1 |  | H | LATIFA E |  | 10-015 | 11-026 | 11 -035 |  | 11-027 | APP | 09-026 |  |  |  |  |  |  |  |  |  |  |  |  |  |  |  |  |  |  |  |  |  |
| 142213022 |  | P-#1 Proc Wires, Pins and Feedthroughs LABOR |  | 211d | 2009-05-06 A | 2010-03-15 A | 9-090M FS+145d | 100% |  |  | MECH TECH [472 h]; CONTRB UNIV LBR [160 h] | 19,404.05 | 19,404.05 |  |  | 0 | 19092.4 | ELOUADRHIRI L | 1 | 1 |  | H | LATIFA E |  | 10-015 | 11-026 | 11 -035 |  | 11-027 | APP | 09-026 | 08-046 |  |  |  |  |  |  |  |  |  |  |  |  |  |  |  |  |  |  |  |  |
| 142213022P |  | P-#1 Proc Wires, Pins and Feedthroughs |  | 287d | 2009-05-06 A | 2010-06-30 A | 9-090M FS+145d | 100% |  |  | PROCUREMENT<$50K 60 NO ESCALATION FY10; PROCUREMENT>$50K 69 NO ESCALATION FY10 | 601,100 |  |  |  | 0 | 601100 | ELOUADRHIRI L | 1 | 1 |  | D | LATIFA E |  | 10-015 | 11-026 | 11 -035 |  | 11-027 | APP | 09-026 | 08-046 | 0 | 601100 | 60110000 | 100 |  |  |  |  |  |  |  |  |  |  |  |  |  |  |  |  |
| 142213030 |  | P-#1 Proc Circuit Boards LABOR |  | 111d | 2009-05-06 A | 2009-10-12 A | 9-090M FS+145d | 100% |  |  | ELEC ENG [40 h]; ELEC TECH [40 h]; ELEC DES [704 h] | 36,629.57 | 36,629.57 |  |  | 0 | 36545.92 | ELOUADRHIRI L | 1 | 1 |  | H | LATIFA E |  | 10-015 | 11-026 | 11 -035 |  | 11-027 | APP | 09-026 |  |  |  |  |  |  |  |  |  |  |  |  |  |  |  |  |  |  |  |  |  |
| 142213030P |  | P-#1 Proc Circuit Boards |  | 102d | 2009-05-06 A | 2009-09-29 A | 9-090M | 100% |  |  | PROCUREMENT<$50K 60 NO ESCALATION FY10 | 17,200 |  |  |  | 0 | 17200 | ELOUADRHIRI L | 1 | 1 |  | S | LATIFA E |  | 10-015 | 11-026 | 11 -035 |  | 11-027 | APP | 09-026 |  | 0 | 17200 | 1720000 | 100 | ST |  |  |  |  |  |  |  |  |  |  |  |  |  |  |  |
| 142213017P |  | P-#1 Proc Frames/Endplates |  | 195d | 2009-05-13 A | 2010-02-26 A | 9-090M FS+150d | 100% |  |  | PROCUREMENT<$50K 60 NO ESCALATION FY10 | 93,800 |  |  |  | 0 | 93800 | ELOUADRHIRI L | 1 | 1 |  | S | LATIFA E |  | 10-015 | 11-026 | 11 -035 |  | 11-027 | APP | 09-026 |  | 0 | 93800 | 9380000 | 100 | ST |  |  |  |  |  |  |  |  |  |  |  |  |  |  |  |
| 142213020P |  | P-#1 Proc Box Assy. & Fixtures |  | 175.99d | 2009-05-13 A | 2010-01-29 A | 9-090M FS+155d | 100% |  |  | PROCUREMENT<$50K 60 | 57,800 |  |  |  | 0 | 57800 | ELOUADRHIRI L | 1 | 1 |  | D | LATIFA E |  | 10-015 | 11-026 | 11 -035 |  | 11-027 | APP | 09-026 |  | 0 | 57800 | 5780000 | 100 |  |  |  |  |  |  |  |  |  |  |  |  |  |  |  |  |
| 142213035 |  | P-#1 Build Stringing Fixtures, Machines and Platforms |  | 198d | 2009-06-01 A | 2010-03-19 A | 9-090M | 100% |  |  | PLABOR; SKLLD TRADE [64 h]; CONTRB UNIV LBR [360 h]; MECH TECH [218.4 h]; MECH ENG [206 h] | 39,360.14 | 24,360.14 |  |  | 0 | 38927.94 | ELOUADRHIRI L | 1 | 1 |  | H | LATIFA E |  | 10-015 | 11-026 | 11 -035 |  | 11-027 | APP | 09-026 |  |  |  |  |  |  | 08-016 | 09-012 |  |  |  |  |  |  |  |  |  |  |  |  |  |
| 142213035P |  | P-#1 Proc Cleanroom Fixtures and Equipment |  | 141d | 2009-06-01 A | 2009-12-21 A | 9-090M FS+170d | 100% | 2009-06-01 | 2009-12-18 | PROCUREMENT<$50K 60 | 70,400 |  |  |  | 0 | 70400 | ELOUADRHIRI L | 1 | 1 |  | D | LATIFA E |  | 10-015 | 11-026 | 11 -035 |  | 11-027 | APP | 09-026 |  | 0 | 70400 | 7040000 | 100 |  | 08-016 |  |  |  |  |  |  |  |  |  |  |  |  |  |  |
| 142213017A |  | P-#1 Proc Endplates & Frames LABOR Final FY09 |  | 157d | 2009-07-01 A | 2010-02-22 A | 142213017 | 100% |  |  | CONTRB UNIV LBR [59.64 h]; MECH TECH [199.89 h] | 8,238.29 | 8,238.29 |  |  | 0 | 8085.5505 | ELOUADRHIRI L | 1 | 1 |  | H | LATIFA E |  | 10-015 | 11-026 | 11 -035 |  |  | APP | 09-026 |  |  |  |  |  |  |  |  | 10-001B |  |  |  |  |  |  |  |  |  |  |  |  |
| 142213017Ab |  | P-#1 Proc Endplates & Frames LABOR Final FY10 |  | 93d | 2009-09-30 A | 2010-02-22 A | 142213017A FS-300d | 100% | 2009-09-30 | 2010-02-19 | CONTRB UNIV LBR [11.25 h]; MECH TECH [37.71 h] | 1,573.49 | 1,573.8 |  |  | 0 | 1574.0154 | ELOUADRHIRI L | 1 | 1 |  | H | LATIFA E |  | 10-015 | 11-026 | 11 -035 |  |  | APP |  |  |  |  |  |  |  |  |  | 10-001B |  |  |  |  |  |  |  |  |  |  |  |  |
| 142213010E |  | FY10 Travel (FWD Chambers) |  | 248d | 2009-10-01 A | 2010-09-30 A | 142213009E | 100% |  |  | TRAVEL | 2,746.96 |  | 100 | 100 | 0 | 2746.959076 | ELOUADRHIRI L | 1 | 1 | 07-024 | E | LATIFA E |  | 10-015 | 11-026 | 11 -035 |  |  |  |  |  |  |  |  |  |  |  |  |  |  |  |  |  |  |  |  |  |  |  |  |  |
| 142213100M |  | P-#2 Constrction Start P-#2 | milestone | 0d | 2009-10-01 A | 2009-10-01 A | 9-100M | 100% | 2009-11-06 | 2009-11-06 |  |  |  |  |  |  | 0 | ELOUADRHIRI L | 1 | 1 |  | M | LATIFA E |  | 10-015 | 11-026 | 11 -035 | 6 | 11-027 |  | 09-026 |  |  |  |  |  |  |  |  |  | 11-038 |  |  |  |  |  |  |  |  |  |  |  |
| 142213122P |  | P-#2 Proc Wires, Pins and Feedthroughs |  | 173d | 2009-10-01 A | 2010-06-15 A | 142213100M FS+10d | 100% |  |  | PROCUREMENT<$50K 60 | 10,319 |  |  |  | 0 | 10319 | ELOUADRHIRI L | 1 | 1 |  | D | LATIFA E |  | 10-015 | 11-026 | 11 -035 |  | 11-027 | APP | 09-026 |  | 0 | 10319 | 1031900 | 100 |  |  |  |  |  | 08-043 |  |  |  |  |  |  |  |  |  |  |
| 142213042 |  | P-#1 String Chambers Initial |  | 174d | 2009-10-12 A | 2010-06-28 A | 142213035, 142213030 FS-175d, 9-100M, 142213035P FS-175d, 142213030P FS-175d, 142213022 FS-150d, 142213022P FS-100d, 142213032 | 100% | 2009-10-12 | 2010-06-25 | CONTRB UNIV LBR [123.45 h]; MECH TECH [437.02 h]; MECH ENG [108.02 h]; PLABOR; PD UNIV STAFF [493.79 h]; SCIENTIST [9.26 h] | 101,207.56 | 52,733.93 |  |  | 0 | 101207.5607 | ELOUADRHIRI L | 1 | 1 |  | S | LATIFA E |  | 10-015 | 11-026 | 11 -035 |  | 11-027 |  | 09-026 |  |  |  |  |  | ST |  |  |  |  |  |  |  |  |  |  |  |  |  |  |  |
| 142213122 |  | P-#2 Proc Wires, Pins and Feedthroughs LABOR |  | 98d | 2009-10-15 A | 2010-03-15 A | 142213100M | 100% |  |  | MECH TECH [8 h]; CONTRB UNIV LBR [80 h] | 333.92 | 333.92 |  |  | 0 | 333.92 | ELOUADRHIRI L | 1 | 1 |  | H | LATIFA E |  | 10-015 | 11-026 | 11 -035 |  | 11-027 | APP | 09-026 |  |  |  |  |  |  |  |  |  |  | 08-043 |  |  |  |  |  |  |  |  |  |  |
| 142213117 |  | P-#2 Proc Endplates & Frames LABOR Initial |  | 162d | 2009-10-28 A | 2010-06-25 A | 142213017Ab FS-250d | 100% |  |  | CONTRB UNIV LBR [40 h]; MECH TECH [560 h] | 23,374.4 | 23,374.4 |  |  | 0 | 23374.4 | ELOUADRHIRI L | 1 | 1 |  | H | LATIFA E |  | 10-015 | 11-026 | 11 -035 |  |  | APP | 09-026 |  |  |  |  |  |  |  |  |  |  |  |  |  |  |  |  |  |  |  |  |  |
| 142213135 |  | P-#2 Build Stringing Fixtures, Machines and Platforms |  | 317.4d | 2009-12-14 A | 2011-03-31 A | 142213100M | 100% |  |  | PLABOR; MECH TECH [272.4 h]; MECH ENG [324 h]; SKLLD TRADE [128.8 h] | 75,196.78 | 37,192.96 |  |  | 0 | 74756.092 | ELOUADRHIRI L | 1 | 1 |  | S | LATIFA E |  | 10-015 | 11-026 | 11 -035 |  | 11-027 |  | 09-026 |  |  |  |  |  | ST |  |  |  |  | 08-043 |  |  |  |  |  |  |  |  |  |  |
| 142213117P |  | P-#2 Proc Frames/Endplates |  | 551d | 2009-12-21 A | 2012-03-19 A | 142213100M FS+26d | 100% | 2009-12-28 | 2012-03-16 | PROCUREMENT>$50K 69; PROCUREMENT<$50K 60 | 225,986.1 |  |  |  | 0 | 225986.1 | ELOUADRHIRI L | 1 | 1 |  | S | LATIFA E |  | 10-015 | 11-026 | 11 -035 |  | 11-027 | APP | 09-026 |  | 0 | 225986.1 | 22598610 | 100 | ST |  |  |  | 11-038 |  |  |  |  |  |  |  |  |  |  |  |
| 142213120 |  | P-#2 Proc Box Assy. Fixtures LABOR |  | 165d | 2009-12-21 A | 2010-08-20 A | 142213100M FS+46d | 100% | 2009-12-28 | 2010-08-20 | MECH TECH [360 h] | 15,026.4 | 15,026.4 |  |  | 0 | 15026.4 | ELOUADRHIRI L | 1 | 1 |  | H | LATIFA E |  | 10-015 | 11-026 | 11 -035 |  | 11-027 | APP | 09-026 |  |  |  |  |  |  |  |  |  | 11-038 |  |  |  |  |  |  |  |  |  |  |  |
| 142213120P |  | P-#2 Proc Box Assy. Fixtures |  | 477d | 2009-12-21 A | 2011-11-21 A | 142213100M FS+67d | 100% | 2009-12-28 | 2011-11-21 | PROCUREMENT<$50K 60 | 87,298.74 |  |  |  | 0 | 87298.74 | ELOUADRHIRI L | 1 | 1 |  | D | LATIFA E |  | 10-015 | 11-026 | 11 -035 |  | 11-027 | APP | 09-026 |  | 0 | 87298.74 | 8729874 | 100 |  |  |  |  | 11-038 |  |  |  |  |  |  |  |  |  |  |  |
| 142213135P |  | P-#2 Proc Cleanroom Fixtures and Equipment |  | 285d | 2009-12-21 A | 2011-02-21 A | 142213100M FS+24d | 100% | 2009-12-28 | 2011-02-18 | PROCUREMENT<$50K 60; PROCUREMENT>$50K 69 | 145,704.28 |  |  |  | 0 | 145704.28 | ELOUADRHIRI L | 1 | 1 |  | D | LATIFA E |  | 10-015 | 11-026 | 11 -035 |  | 11-027 |  | 09-026 |  | 0 | 145704.28 | 14570428 | 100 |  |  |  |  |  | 08-043 |  |  |  |  |  |  |  |  |  |  |
| 142213032 |  | P-#1 Build Boxes and Associated Hardware |  | 35d | 2010-01-29 A | 2010-03-19 A | 142213017P FS-200d, 142213020P FS-120d, 142213020 FS-100d, 142213017Ab FS-120d, 9-100M | 100% |  |  | MECH ENG [188 h]; MECH TECH [284.4 h]; PD UNIV STAFF [80 h]; SKLLD TRADE [120 h]; PLABOR | 58,040.16 | 32,242.66 |  |  | 0 | 58040.156 | ELOUADRHIRI L | 1 | 1 |  | S | LATIFA E |  | 10-015 | 11-026 | 11 -035 |  | 11-027 |  | 09-026 |  |  |  |  |  | ST |  |  |  |  |  |  |  |  |  |  |  |  |  |  |  |
| 142213130 |  | P-#2 Proc Circuit Boards LABOR |  | 487d | 2010-02-26 A | 2012-02-13 A | 142213100M FS+80d | 100% |  |  | ELEC TECH [40 h] | 1,704.04 | 1,704.04 |  |  | 0 | 1658 | ELOUADRHIRI L | 1 | 1 |  | H | LATIFA E |  | 10-015 | 11-026 | 11 -035 |  | 11-027 | APP | 09-026 |  |  |  |  |  |  |  |  |  |  | 08-043 |  |  |  |  |  |  |  |  |  |  |
| 142213042M |  | First Wire Strung | milestone | 0d | 2010-04-22 A | 2010-04-22 A | 142213042 FS-150d | 100% | 2010-05-17 | 2010-05-17 |  |  |  |  |  |  | 0 | ELOUADRHIRI L | 1 | 1 |  | M | LATIFA E |  | 10-015 | 11-026 | 11 -035 |  |  |  | 09-026 |  |  |  |  |  |  |  |  |  |  |  |  |  |  |  |  |  |  |  |  |  |
| 142213130P |  | P-#2 Proc Circuit Boards Initial |  | 47d | 2010-04-26 A | 2010-06-30 A | 142213100M SS+90d | 100% |  |  | PROCUREMENT<$50K 60 | 54,310.96 |  |  |  | 0 | 54310.96 | ELOUADRHIRI L | 1 | 1 |  | S | LATIFA E |  | 10-015 | 11-026 | 11 -035 |  | 11-027 | APP | 09-026 |  | 0 | 54310.96 | 5431096 | 100 | ST |  |  |  |  | 08-043 |  |  |  |  |  |  |  |  |  |  |
| 142213042B |  | P-#1 String Chambers Final FY10 |  | 106d | 2010-06-01 A | 2010-10-29 A | 142213042 | 100% | 2010-06-01 | 2010-10-28 | MECH ENG [112.9 h]; PLABOR; PD UNIV STAFF [516.13 h]; SCIENTIST [9.68 h]; CONTRB UNIV LBR [129.03 h]; MECH TECH [456.31 h] | 63,056.43 | 54,762.5 |  |  | 0 | 62729.7153 | ELOUADRHIRI L | 1 | 1 |  | D | LATIFA E |  | 10-015 | 11-026 | 11 -035 |  | 11-027 |  | 09-026 |  |  |  |  |  |  |  |  |  |  |  | 11-001 |  |  |  |  |  |  |  |  |  |
| 142213042Ba |  | P-#1 String Chambers Final FY11 |  | 159d | 2010-06-01 A | 2011-01-24 A | 142213042B FS-131d | 100% |  |  | PLABOR; PD UNIV STAFF [270.07 h]; SCIENTIST [5.06 h]; CONTRB UNIV LBR [67.52 h]; MECH TECH [238.77 h]; MECH ENG [59.08 h] | 33,379.58 | 28,859.79 |  |  | 0 | 33869.6672 | ELOUADRHIRI L | 1 | 1 |  | D | LATIFA E |  | 10-015 | 11-026 | 11 -035 |  | 11-027 |  | 09-026 |  |  |  |  |  |  |  |  |  |  |  | 11-001 |  |  |  |  |  |  |  |  |  |
| 142213045 |  | ODU Contract Preperations |  | 33d | 2010-06-01 A | 2010-07-16 A | 9-100M FS+162d | 100% |  |  | CONTRB UNIV LBR [200 h]; MECH TECH [49.6 h] | 2,070.3 | 2,070.3 |  |  | 0 | 2070.304 | ELOUADRHIRI L | 1 | 1 |  | H | LATIFA E |  | 10-015 | 11-026 | 11 -035 |  |  |  | 09-026 |  |  |  |  |  |  |  |  |  |  |  |  | 11-010 |  |  |  |  |  |  |  |  |
| 142213070 |  | ISU Contract Preperations FY10 |  | 122.26d | 2010-06-01 A | 2010-11-22 A | 9-100M FS+162d | 100% |  |  | MECH TECH [48.47 h]; CONTRB UNIV LBR [195.45 h] | 2,042.26 | 2,042.26 |  |  | 0 | 2023.1378 | ELOUADRHIRI L | 1 | 1 |  | H | LATIFA E |  | 10-015 | 11-026 | 11 -035 |  |  |  | 09-026 |  |  |  |  |  |  |  |  |  |  |  | 11-001 |  | 11-031 |  |  |  |  |  |  |  |
| 142213070a |  | ISU Contract Preperations FY11 |  | 123d | 2010-06-01 A | 2010-11-22 A | 142213070 | 100% |  |  | MECH TECH [1.13 h]; CONTRB UNIV LBR [4.55 h] | 47.62 | 47.62 |  |  | 0 | 48.6691 | ELOUADRHIRI L | 1 | 1 |  | H | LATIFA E |  | 10-015 | 11-026 | 11 -035 |  |  |  | 09-026 |  |  |  |  |  |  |  |  |  |  |  | 11-001 |  | 11-031 |  |  |  |  |  |  |  |
| 142213117B |  | P-#2/3 Proc Endplates & Frames LABOR Final FY10 |  | 470d | 2010-06-28 A | 2012-05-21 A | 142213117, 142213017Ab | 100% | 2010-06-28 | 2012-05-18 | MECH DES [82.3 h]; MECH ENG [25.72 h]; MECH TECH [5.14 h] | 5,846.97 | 5,875.26 | 100 | 100 | 0 | 5631.4576 | ELOUADRHIRI L | 1 | 1 |  | E | LATIFA E |  | 10-015 | 11-026 | 11 -035 |  |  | APP | 09-026 |  |  |  |  |  |  |  |  |  |  |  | 11-001 |  |  | 8.25335892 | 91.74664107 |  |  |  |  |  |
| 142213117Ba |  | P-#2/3 Proc Endplates & Frames LABOR Final FY11 |  | 471d | 2010-06-28 A | 2012-05-21 A | 142213017Ab, 142213117 | 100% |  |  | MECH DES [304.65 h]; MECH ENG [95.2 h]; MECH TECH [19.04 h] | 21,642.91 | 21,642.91 | 100 | 100 | 0 | 21509.954387 | ELOUADRHIRI L | 1 | 1 |  | E | LATIFA E |  | 10-015 | 11-026 | 11 -035 |  |  | APP | 09-026 |  |  |  |  |  |  |  |  |  |  |  | 11-001 |  |  | 17.33870967 | 82.66129032 | 12-001 |  |  |  |  |
| 142213117Bb |  | P-#2 Proc Endplates & Frames LABOR Final FY12 |  | 471d | 2010-06-28 A | 2012-05-21 A | 142213117Ba FS-210d | 100% |  |  | MECH DES [253.05 h]; MECH ENG [79.08 h]; MECH TECH [15.82 h] | 17,977.67 | 17,977.67 | 100 | 100 | 0 | 18437.548473 | ELOUADRHIRI L | 1 | 1 |  | E | LATIFA E |  | 10-015 | 11-026 | 11 -035 |  |  | APP | 09-026 |  |  |  |  |  |  |  |  |  |  |  | 11-001 |  |  | 20.8737864 | 79.12621359 | 12-001 |  |  |  |  |
| 142213130Pb |  | P-#2 Proc Circuit Boards Final |  | 378d | 2010-08-02 A | 2012-02-13 A | 142213130P | 100% |  |  | PROCUREMENT>$50K 69; PROCUREMENT<$50K 60 | 80,000 |  |  |  | 0 | 80000 | ELOUADRHIRI L | 1 | 1 |  | D | LATIFA E |  | 10-015 | 11-026 | 11 -035 |  | 11-027 | APP | 09-026 |  | 0 | 80000 | 8000000 | 100 |  |  |  |  |  | 08-043 |  |  |  |  |  |  |  |  |  |  |
| 142213132 |  | P-#2 Build Boxes and Associated Hardware Part A |  | 229d | 2010-08-23 A | 2011-07-26 A | 142213120P FS-160d, 142213100M, 142213117P FS-100d, 9-110M FS-20d, 142213120, 142213117 FS-170d | 100% |  |  | MECH TECH [1795.64 h]; PLABOR; SKLLD TRADE [145.36 h]; MECH ENG [149.64 h]; CONTRB UNIV LBR [64.13 h] | 131,530.36 | 91,870.63 |  |  | 0 | 132052.584 | ELOUADRHIRI L | 1 | 1 |  | S | LATIFA E |  | 10-015 | 11-026 | 11 -035 |  | 11-027 |  | 09-026 |  |  |  |  |  | ST |  |  |  | 11-038 | 08-043 |  |  |  |  |  |  |  |  |  |  |
| 142213230P |  | P-#3 Proc Circuit Boards |  | 510d | 2010-09-27 A | 2012-10-15 A | 9-110M, 142213200M | 100% |  |  | PROCUREMENT<$50K 60 NO ESCALATION FY12; PROCUREMENT>$50K 69 NO ESCALATION FY12 | 82,552 |  |  |  | 0 | 82552 | ELOUADRHIRI L | 1 | 1 |  | D | LATIFA E |  | 10-015 | 11-026 | 11 -035 |  | 11-027 | APP | 09-026 |  | 0 | 82552 | 8255200 | 100 |  |  |  |  |  | 08-043 |  |  |  |  |  |  |  |  |  |  |
| 142213011E |  | FY11 Travel (FWD Chambers) |  | 248d | 2010-10-01 A | 2011-09-30 A | 142213010E | 100% |  |  | TRAVEL | 18,174.34 |  | 100 | 100 | 0 | 18174.34 | ELOUADRHIRI L | 1 | 1 | 07-024 | E | LATIFA E |  | 10-015 | 11-026 | 11 -035 |  |  |  |  |  |  |  |  |  |  |  |  |  |  |  |  |  |  | 8.46774193 | 91.53225806 |  |  |  |  |  |
| 142213200M |  | P-#3 Constrction Start P-#3 | milestone | 0d | 2010-10-01 A | 2010-10-01 A | 9-110M | 100% | 2010-11-01 | 2010-11-01 |  |  |  |  |  |  | 0 | ELOUADRHIRI L | 1 | 1 |  | M | LATIFA E |  | 10-015 | 11-026 | 11 -035 | 6 | 11-027 |  | 09-026 |  |  |  |  |  |  |  |  |  |  | 08-043 |  |  |  |  |  |  |  |  |  |  |
| 142213330P |  | P-#4 Proc Circuit Boards |  | 551d | 2010-10-03 A | 2013-02-11 A | 142213300M FS-225d | 100% | 2010-10-04 | 2012-12-20 | PROCUREMENT>$50K 69; PROCUREMENT<$50K 60 | 179,465.95 |  |  |  | 0 | 179465.95 | ELOUADRHIRI L | 1 | 1 |  | D | LATIFA E |  | 10-015 | 11-026 | 11 -035 |  | 11-027 | APP | 09-026 |  | 0 | 179465.95 | 17946595 | 100 |  |  |  |  |  | 08-043 |  |  |  |  |  |  |  |  |  |  |
| 142213230 |  | P-#3 Proc Circuit Boards LABOR |  | 505d | 2010-10-04 A | 2012-10-15 A | 9-110M, 142213200M | 100% |  |  | CONTRB UNIV LBR [144 h]; MECH TECH [40 h] | 1,752.03 | 1,752.03 |  |  | 0 | 1722.8 | ELOUADRHIRI L | 1 | 1 |  | H | LATIFA E |  | 10-015 | 11-026 | 11 -035 |  | 11-027 | APP | 09-026 |  |  |  |  |  |  |  |  |  |  | 08-043 |  |  |  |  |  |  |  |  |  |  |
| 142213050 |  | ODU Contract Peg Point #1 Boxes Built & Ready to String |  | 238d | 2010-10-15 A | 2011-09-30 A | 142213045 FS+58d | 100% |  |  | PROCUREMENT>$50K 69 NO ESCALATION; PROCUREMENT<$50K 60 NO ESCALATION | 105,000 |  |  |  | 0 | 105000 | ELOUADRHIRI L | 1 | 1 |  | D | LATIFA E |  | 10-015 | 11-026 | 11 -035 |  |  |  | 09-026 |  | 0 | 105000 | 10500000 | 100 |  |  |  |  |  |  |  | 11-010 |  |  |  |  |  |  |  |  |
| 142213055 |  | ODU Contract Peg Point #2 Hire and Train First two Stringers |  | 90d | 2010-12-01 A | 2011-04-15 A | 142213050 FS-207d | 100% |  |  | PROCUREMENT>$50K 69 NO ESCALATION | 118,000 |  |  |  | 0 | 118000 | ELOUADRHIRI L | 1 | 1 |  | D | LATIFA E |  | 10-015 | 11-026 | 11 -035 |  |  |  | 09-026 |  | 0 | 118000 | 11800000 | 100 |  |  |  |  |  |  |  | 11-010 |  |  |  |  |  |  |  |  |
| 142213222 |  | P-#3 Proc Wires, Pins and Feedthroughs LABOR |  | 100d | 2010-12-01 A | 2011-04-29 A | 9-110M | 100% |  |  | MECH TECH [120 h]; SCIENTIST [12 h]; CONTRB UNIV LBR [24 h] | 5,989.56 | 5,989.56 |  |  | 0 | 5989.56 | ELOUADRHIRI L | 1 | 1 |  | H | LATIFA E |  | 10-015 | 11-026 | 11 -035 |  | 11-027 | APP | 09-026 |  |  |  |  |  |  |  |  |  |  |  |  |  |  |  |  |  |  |  |  |  |
| 142213060 |  | ODU Contract Peg Point #3 Hire and Train Second two Stringers |  | 103d | 2011-03-01 A | 2011-07-25 A | 142213055 FS-84d | 100% |  |  | PROCUREMENT>$50K 69 NO ESCALATION; PROCUREMENT<$50K 60 NO ESCALATION | 81,914.64 |  |  |  | 0 | 81914.64 | ELOUADRHIRI L | 1 | 1 |  | D | LATIFA E |  | 10-015 | 11-026 | 11 -035 |  |  |  | 09-026 |  | 0 | 81914.64 | 8191464 | 100 |  |  |  |  |  |  |  | 11-010 |  |  |  |  |  |  |  |  |
| 142213062 |  | ODU Contract Peg Point #4 String and Test all wires on RII chamber #2 |  | 194d | 2011-03-01 A | 2011-12-02 A | 142213060 FS-170d | 100% |  |  | PROCUREMENT<$50K 60 NO ESCALATION; PROCUREMENT>$50K 69 NO ESCALATION | 91,829.27 |  |  |  | 0 | 91829.27 | ELOUADRHIRI L | 1 | 1 |  | D | LATIFA E |  | 10-015 | 11-026 | 11 -035 |  |  |  | 09-026 |  | 0 | 91829.27 | 9182927 | 100 |  |  |  |  |  |  |  | 11-010 |  |  |  |  |  |  |  |  |
| 142213064 |  | ODU Contract Peg Point #5 String and Test all wires on RII chamber #3 |  | 365d | 2011-03-01 A | 2012-08-13 A | 142213062 FS-210d | 100% |  |  | PROCUREMENT>$50K 69 NO ESCALATION | 71,371.95 |  |  |  | 0 | 71371.95 | ELOUADRHIRI L | 1 | 1 |  | D | LATIFA E |  | 10-015 | 11-026 | 11 -035 |  |  |  | 09-026 |  | 0 | 71371.95 | 7137195 | 100 |  |  |  |  |  |  |  | 11-010 |  |  |  |  | MP |  |  |  |
| 142213133 |  | P-#2 Build Boxes and Associated Hardware Part B (Frozen by Administrative CR 11-38) |  | 44.61d | 2011-03-01 A | 2011-05-02 A | 142213132 FS-60d | 100% |  |  | PLABOR; SKLLD TRADE [9.2 h]; MECH ENG [38.24 h]; CONTRB UNIV LBR [16.39 h]; MECH TECH [458.88 h] | 25,180.36 | 24,315.65 |  |  | 0 | 25180.3636 | ELOUADRHIRI L | 1 | 1 |  | S | LATIFA E |  | 10-015 | 11-026 | 11 -035 |  | 11-027 |  | 09-026 |  |  |  |  |  | ST |  |  |  | 11-038 | 08-043 |  |  |  |  |  |  |  |  |  |  |
| 142213142 |  | P-#2 String Chambers Part A |  | 259d | 2011-04-01 A | 2012-04-16 A | 142213130P, 142213122P, 142213042Ba, 142213130 FS-120d, 142213135, 142213100M, 142213122, 142213135P, 142213130Pb FS-120d | 100% |  |  | MECH TECH [349.52 h]; PLABOR | 59,363.18 | 15,358.05 |  |  | 0 | 59120.9864 | ELOUADRHIRI L | 1 | 1 |  | S | LATIFA E |  | 10-015 | 11-026 | 11 -035 |  | 11-027 |  | 09-026 |  |  |  |  |  | ST |  | 09-012 |  |  | 08-043 |  |  |  |  |  |  |  |  |  |  |
| 142213235P |  | P-#3 Proc Cleanroom Fixtures and Equipment |  | 164d | 2011-04-01 A | 2011-11-21 A | 9-120M FS-110d | 100% |  |  | PROCUREMENT<$50K 60 | 87,528.01 |  |  |  | 0 | 87528.01 | ELOUADRHIRI L | 1 | 1 |  | D | LATIFA E |  | 10-015 | 11-026 | 11 -035 |  | 11-027 |  | 09-026 |  | 0 | 87528.01 | 8752801 | 100 |  |  |  |  |  | 08-043 |  |  |  |  |  |  |  |  |  |  |
| 142213220P |  | P-#3 Proc Box Assy. Fixtures |  | 194d | 2011-04-02 A | 2012-01-16 A | 9-110M FS+23d | 100% | 2011-04-04 | 2012-01-13 | PROCUREMENT<$50K 60 | 29,925.1 |  |  |  | 0 | 29925.1 | ELOUADRHIRI L | 1 | 1 |  | D | LATIFA E |  | 10-015 | 11-026 | 11 -035 |  | 11-027 | APP | 09-026 |  | 0 | 29925.1 | 2992510 | 100 |  |  |  |  |  |  |  |  |  |  |  |  |  |  |  |  |
| 142213222P |  | P-#3 Proc Wires, Pins and Feedthroughs |  | 194d | 2011-04-02 A | 2012-01-16 A | 9-110M | 100% | 2011-04-04 | 2012-01-13 | PROCUREMENT<$50K 60 | 10,319 |  |  |  | 0 | 10319 | ELOUADRHIRI L | 1 | 1 |  | D | LATIFA E |  | 10-015 | 11-026 | 11 -035 |  | 11-027 | APP | 09-026 |  | 0 | 10319 | 1031900 | 100 |  |  |  |  |  |  |  |  |  |  |  |  |  |  |  |  |
| 142213235 |  | P-#3 Build Stringing Fixtures, Machines and Platforms FY11 |  | 621d | 2011-04-02 A | 2013-02-11 A | 9-110M FS+100d, 142213135 | 100% | 2011-04-04 | 2013-09-27 | MECH TECH [150.41 h]; MECH DES [300.81 h]; MECH ENG [138.37 h] | 31,074.02 | 30,798.62 |  |  | 0 | 29922.211 | ELOUADRHIRI L | 1 | 1 |  | S | LATIFA E |  | 10-015 | 11-026 | 11 -035 |  | 11-027 |  | 09-026 |  |  |  |  |  | ST |  |  |  |  | 08-043 |  |  |  |  |  | 12-001 |  | OPC A |  |  |
| 142213235a |  | P-#3 Build Stringing Fixtures, Machines and Platforms FY12 |  | 621d | 2011-04-02 A | 2013-02-11 A | 142213235 FS-290d | 100% | 2011-04-04 | 2013-09-27 | MECH TECH [99.59 h]; MECH ENG [91.63 h]; MECH DES [199.19 h] | 20,576.49 | 20,395.04 |  |  | 0 | 20445.8575 | ELOUADRHIRI L | 1 | 1 |  | S | LATIFA E |  | 10-015 | 11-026 | 11 -035 |  | 11-027 |  | 09-026 |  |  |  |  |  | ST |  |  |  |  | 08-043 |  |  |  |  |  | 12-001 |  | OPC A |  |  |
| 142213075 |  | ISU Contract Phase 1a - Hire lead stringer, complete cleanroom, Readiness Review |  | 101d | 2011-04-11 A | 2011-08-31 A | 142213070a FS-9d | 100% |  |  | PROCUREMENT<$50K 60; PROCUREMENT>$50K 69 | 127,253.91 |  |  |  | 0 | 127253.91 | ELOUADRHIRI L | 1 | 1 |  | D | LATIFA E |  | 10-015 | 11-026 | 11 -035 |  |  |  | 09-026 |  | 0 | 127253.91 | 12725391 | 100 |  |  |  |  |  |  |  |  | 11-031 |  |  |  |  |  |  |  |
| 142213080 |  | ISU Contract Phase 1b - Hire and train first 2 stringers, install and tension chamber 2 |  | 99d | 2011-04-11 A | 2011-08-29 A | 142213075 FS-110d | 100% |  |  | PROCUREMENT>$50K 69 NO ESCALATION | 37,746.09 |  |  |  | 0 | 37746.09 | ELOUADRHIRI L | 1 | 1 |  | D | LATIFA E |  | 10-015 | 11-026 | 11 -035 |  | 11-027 |  | 09-026 |  | 0 | 37746.09 | 3774609 | 100 |  |  |  |  |  |  |  |  | 11-031 |  |  |  |  |  |  |  |
| 142213133C |  | P-#2 Build Boxes and Associated Hardware Part B FY12 (Revised by Administrative CR 11-38) |  | 701d | 2011-05-02 A | 2013-08-30 A | 142213133b FS-625d | 100% | 2011-05-02 | 2014-02-28 | MECH TECH [687.54 h]; PLABOR; SKLLD TRADE [55.66 h]; MECH ENG [57.29 h]; CONTRB UNIV LBR [24.55 h] | 51,440.84 | 37,183.26 |  |  | 3182.4956234 | 52172.0594 | ELOUADRHIRI L | 1 | 1 |  | S | LATIFA E |  | 10-015 | 11-026 | 11 -035 |  | 11-027 |  | 09-026 |  |  |  |  |  | ST |  |  |  | 11-038 | 08-043 |  |  |  |  |  |  |  | OPC A | 12-053 |  |
| 142213133Ca |  | P-#2 Build Boxes and Associated Hardware Part B FY13 |  | 701d | 2011-05-02 A | 2013-08-30 A | 142213133C FS-370d | 100% | 2011-05-02 | 2014-02-28 | MECH ENG [48.25 h]; CONTRB UNIV LBR [20.68 h]; MECH TECH [578.98 h]; PLABOR; SKLLD TRADE [46.87 h] | 44,840.74 | 30,891.07 |  |  | 2765.60855719 | 45337.8452 | ELOUADRHIRI L | 1 | 1 |  | S | LATIFA E |  | 10-015 | 11-026 | 11 -035 |  | 11-027 |  | 09-026 |  |  |  |  |  | ST |  |  |  | 11-038 | 08-043 |  |  |  |  |  |  |  |  | 12-053 |  |
| 142213133a |  | Reverse Entry per Administrative CR 11-38 |  | 1d | 2011-05-02 A | 2011-05-02 A | 9-110M FS+141d | 100% |  |  | SKLLD TRADE [-9.2 h]; MECH ENG [-38.24 h]; CONTRB UNIV LBR [-16.39 h]; MECH TECH [-458.8 h]; PLABOR | -25,380.89 | -22,861.16 |  |  |  |  | ELOUADRHIRI L | 1 | 1 |  | S | LATIFA E |  | 10-015 | 11-026 |  |  | 11-027 |  | 09-026 |  |  |  |  |  | ST |  |  |  | 11-038 | 08-043 |  |  |  |  |  |  |  |  |  |  |
| 142213133b |  | P-#2 Build Boxes and Associated Hardware Part B FY11 (Revised by Administrative CR 11-38) |  | 701d | 2011-05-02 A | 2013-08-30 A | 142213132 FS-70d, 9-110M FS+141d | 100% | 2011-05-02 | 2014-02-28 | SKLLD TRADE [24.11 h]; MECH ENG [24.82 h]; CONTRB UNIV LBR [10.64 h]; MECH TECH [297.84 h]; PLABOR | 22,073.35 | 15,890.27 |  |  | 1336.106424 | 21903.384 | ELOUADRHIRI L | 1 | 1 |  | S | LATIFA E |  | 10-015 | 11-026 | 11 -035 |  | 11-027 |  | 09-026 |  |  |  |  |  | ST |  |  |  | 11-038 | 08-043 |  |  |  |  |  |  |  | OPC A |  |  |
| 142213220 |  | P-#3 Proc Box Assy. Fixtures LABOR |  | 43d | 2011-05-02 A | 2011-06-30 A | 9-110M | 100% |  |  | MECH TECH [64 h]; SKLLD TRADE [8 h]; MECH ENG [8 h] | 3,559.44 | 3,559.44 |  |  | 0 | 3559.44 | ELOUADRHIRI L | 1 | 1 |  | H | LATIFA E |  | 10-015 | 11-026 | 11 -035 |  |  | APP | 09-026 |  |  |  |  |  |  |  |  |  |  |  |  |  |  |  |  |  |  |  |  |  |
| 142213217P |  | P-#3 Proc Frames/Endplates |  | 217d | 2011-06-01 A | 2012-04-16 A | 142213117P FS-45d | 100% |  |  | PROCUREMENT<$50K 60 NO ESCALATION FY11 | 105,614 |  |  |  | 0 | 105614 | ELOUADRHIRI L | 1 | 1 |  | D | LATIFA E |  | 10-015 | 11-026 | 11 -035 |  | 11-027 | APP | 09-026 |  | 0 | 105614 | 10561400 | 100 |  |  |  |  |  |  |  |  |  |  |  |  |  |  |  | 10-026 |
| 142213300M |  | P-#4 Constrction Start P-#4 | milestone | 0d | 2011-09-19 A | 2011-09-19 A | 9-120M | 100% | 2011-10-03 | 2011-10-03 |  |  |  |  |  |  | 0 | ELOUADRHIRI L | 1 | 1 |  | M | LATIFA E |  | 10-015 | 11-026 | 11 -035 | 6 |  |  | 09-026 |  |  |  |  |  |  |  |  |  |  | 08-043 |  |  |  |  |  |  |  |  |  |  |
| 142213085 |  | ISU Contract Phase 1c - Hire and train last 2 stringers, string wires and test chamber 2 |  | 190d | 2011-09-30 A | 2012-07-09 A | 142213080 FS-21d | 100% |  |  | PROCUREMENT>$50K 69 NO ESCALATION; PROCUREMENT<$50K 60 NO ESCALATION | 69,570 |  |  |  | 0 | 69570 | ELOUADRHIRI L | 1 | 1 |  | D | LATIFA E |  | 10-015 | 11-026 | 11 -035 |  |  |  | 09-026 |  | 0 | 69570 | 6957000 | 100 |  |  |  |  |  |  |  |  | 11-031 |  |  |  |  |  |  |  |
| 142213012E |  | FY12 Travel (FWD Chambers) |  | 247d | 2011-10-03 A | 2012-09-28 A | 142213011E | 100% |  |  | TRAVEL | 18,754.1 |  | 100 | 100 | 0 | 18754.1 | ELOUADRHIRI L | 1 | 1 | 07-024 | E | LATIFA E |  | 10-015 | 11-026 | 11 -035 |  |  |  |  |  |  |  |  |  |  |  |  |  |  |  |  |  |  | 7.69230769 | 92.3076923 |  |  |  |  |  |

Notes:
- 142213030P: Steps: PR 280700 (done); PR284599 (done)
- 142213017P: Steps: PR 283007 (done); PR283008 (done)
- 142213042: Steps: Hire and train RI lead stringer (done); Hire and train RII lead stringer (done); Hire and train RIII lead stringer (done); Install 1st RII chamber on stringing fixture (done); Install pre-tension harware on 1st RII chamber (done); Rotate 1st RII chamber to installed position (done); Survey and measure 1st RII box assy (done); String all wires on 1st RII chamber (done); Test all wires on 1st RII chamber (done); Pot crimp pins on 1st RII chamber (done); Survey and ficucialize 1st RII chamber (done); Install gas window, Instrument 1st RII chamber (done)
- 142213135: Steps: Build Cleanroom & Chamber Stringing Fixtures LABOR (done); Build R1Stringing Fixtures (done); Build Remaining R2 Stringing Fixture (done); Build R3 Stringing Fixtures (done)
- 142213117P: Steps: RI Frames (done); RI Endplates (done); RI Back, nose, etc. (done); RI Hardware (done); RIII Endplates (done); RI Hardware silver plating (done)
- 142213032: Steps: Build First R2 Box Assy (done); Build First R2 Strongback (done); Build R1, R2 and R3 Alignment Fixture (done)
- 142213130P: Steps: All STBs (not including SIPs) (done); All HVBs (done); STB/HVB test stand (done); All SIPs (done); Hardware/Electronics for upgrades (done)
- 142213132: Steps: Inventory, Clean and Kit remaining RII DC Hardware (done); Pre-assemble remaining RII endplate assemblies (done); Pre-assemble remaining RII Boxes (done); Measure critical RII box dimensions (done); Assemble Remaining RII Strongbacks and Links (done); Final assembly of remaining RII endplates/frames (done); Install remaining RII Feedthroughs (done); Ship RII enplate assys, box parts & strngbks to ODU (done); Inventory, Clean and Kit all RI DC Hardware (done); Pre-assemble 1st RI Box (done); Measure critical RI box dimensions on 1st box (done); Revise RI DC drawings as necessary (done); Assemble RI Strongbacks and Links (done); Final assembly of 1st RI endplates/frames (done); Install 1st RI Feedthroughs (done); Final 1st RI Box Assembly (done); Mount 1st RI Box to Strongback (done)
- 142213133: Steps: Pre-assemble remaining RII endplate assemblies (done); Pre-assemble remaining RII Boxes (done); Final assembly of 4th RII endplates/frames (done); Final assembly of 5th RII endplates/frames (done); Final assembly of 6th RII endplates/frames (done); Ship RII enplate assys, box parts & strngbks to ODU (done); Inventory, Clean and Kit all RIII DC Hardware (done); Pre-assemble 1st RIII Box (done); Measure critical RIII dimensions on 1st box (done); Revise RIII DC drawings as necessary (done); Final assembly of 1st RIII endplates/frames (done); Install 1st RIII Feedthroughs (done); Final RIII 1st Box Assembly (done); Assemble RIII Strongbacks and Links (done); Mount 1st RIII Box to Strongback (done); Pre-assemble remaining RI Boxes (done); Final assembly of 2nd & 3rd RI endplates/frames (done); Final assembly of remaining RI endplates/frames (done); Install 2nd & 3rd RI Feedthroughs (done); Install remaining RI Feedthroughs (done); Final 2nd & 3rd RI Box Assemblys (done); Final remaining RI Box Assemblys (done); Mount remaining RI Boxes to Strongbacks (done); Transport remaining RI boxes & strngbks to ISU (done); Pre-assemble remaining RIII Boxes (done); Final assembly of 2nd RIII endplates/frames (done); Final assembly of 3rd RIII endplates/frames (done); Final assembly of 4th RIII endplates/frames (done); Final assembly of 5th RIII endplates/frames (done); Final assembly of 6th RIII endplates/frames (done); Install 2nd RIII Feedthroughs (done); Install 3rd RIII Feedthroughs (done); Install 4th RIII Feedthroughs (done); Install 5th RIII Feedthroughs (done); Install 6th RIII Feedthroughs (done); Final RIII 2nd Box Assemblys (done); Final RIII 3rd Box Assemblys (done); Final RIII 4th Box Assemblys (done); Final RIII 5th Box Assemblys (done); Final RIII 6th Box Assemblys (done); Mount RIII Boxes to Strongbacks (done)
- 142213142: Steps: Hire and train 1st two RIII stringers (done); Install 1st RI chamber on stringing fixture (done); Install 1st RI pre-tension harware (done); Install Guard wires on 1st RI chamber (done); String and test all SL2 field wires on 1st RI chamber (done); String and test all SL1 field wires on 1st RI chamber (done); String and test all SL2 sense wires on 1st RI chamber (done); String and test all SL1 sense wires on 1st RI chamber (done); Survey and ficucialize 1st RI chamber (done); Test all wires on 1st RI chamber (done); Pot crimp pins on 1st RI chamber (done); Install gas window on 1st RI chamber (done); Instrument and test (HV and signal) 1st RI chamber (done)
- 142213220P: Steps: Installation fixture; RI shipping fixtures; RII shipping fixtures
- 142213235: Steps: Assemble RIII Stringing Fixtures #2 (done); Assemble RIII Stringing Fixtures (done); Load Test RIII Stringing Fixtures (done); Load Test RIII Stringing Fixtures #2 (done); Install RIII Stringing Fixtures (done); ME support, shipping/storage fixtures and methods1 (done); MD support, shipping/storage fixtures and methods (done); ME support, Torus interface (done); MD support, Torus interface (done); ME support, cable trays, cable routing (done); MD support, cable trays, cable routing (done)
- 142213235a: Steps: Assemble RIII Stringing Fixtures #2 (done); Assemble RIII Stringing Fixtures (done); Load Test RIII Stringing Fixtures (done); Load Test RIII Stringing Fixtures #2 (done); Install RIII Stringing Fixtures (done); ME support, shipping/storage fixtures and methods1 (done); MD support, shipping/storage fixtures and methods (done); ME support, Torus interface (done); MD support, Torus interface (done); ME support, cable trays, cable routing (done); MD support, cable trays, cable routing (done)
- 142213133C: Steps: Pre-assemble remaining RII endplate assemblies (done); Pre-assemble remaining RII Boxes (done); Final assembly of 4th RII endplates/frames (done); Final assembly of 5th RII endplates/frames (done); Final assembly of 6th RII endplates/frames (done); Ship RII enplate assys, box parts & strngbks to ODU (done); Inventory, Clean and Kit all RIII DC Hardware (done); Pre-assemble 1st RIII Box (done); Measure critical RIII dimensions on 1st box (done); Revise RIII DC drawings as necessary (done); Final assembly of 1st RIII endplates/frames (done); Install 1st RIII Feedthroughs (done); Final RIII 1st Box Assembly (done); Assemble RIII Strongbacks and Links (done); Mount 1st RIII Box to Strongback (done); Pre-assemble remaining RI Boxes (done); Final assembly of 2nd & 3rd RI endplates/frames (done); Final assembly of remaining RI endplates/frames (done); Install 2nd & 3rd RI Feedthroughs (done); Install remaining RI Feedthroughs (done); Final 2nd & 3rd RI Box Assemblys (done); Final remaining RI Box Assemblys (done); Mount remaining RI Boxes to Strongbacks (done); Transport remaining RI boxes & strngbks to ISU (done); Pre-assemble remaining RIII Boxes (done); Final assembly of 2nd RIII endplates/frames (done); Final assembly of 3rd RIII endplates/frames (done); Final assembly of 4th RIII endplates/frames (done); Final assembly of 5th RIII endplates/frames (done); Final assembly of 6th RIII endplates/frames (done); Install 2nd RIII Feedthroughs (done); Install 3rd RIII Feedthroughs (done); Install 4th RIII Feedthroughs (done); Install 5th RIII Feedthroughs (done); Install 6th RIII Feedthroughs (done); Final RIII 2nd Box Assemblys (done); Final RIII 3rd Box Assemblys (done); Final RIII 4th Box Assemblys (done); Final RIII 5th Box Assemblys (done); Final RIII 6th Box Assemblys (done); Mount RIII Boxes to Strongbacks (done)
- 142213133Ca: Steps: Pre-assemble remaining RII endplate assemblies (done); Pre-assemble remaining RII Boxes (done); Final assembly of 4th RII endplates/frames (done); Final assembly of 5th RII endplates/frames (done); Final assembly of 6th RII endplates/frames (done); Ship RII enplate assys, box parts & strngbks to ODU (done); Inventory, Clean and Kit all RIII DC Hardware (done); Pre-assemble 1st RIII Box (done); Measure critical RIII dimensions on 1st box (done); Revise RIII DC drawings as necessary (done); Final assembly of 1st RIII endplates/frames (done); Install 1st RIII Feedthroughs (done); Final RIII 1st Box Assembly (done); Assemble RIII Strongbacks and Links (done); Mount 1st RIII Box to Strongback (done); Pre-assemble remaining RI Boxes (done); Final assembly of 2nd & 3rd RI endplates/frames (done); Final assembly of remaining RI endplates/frames (done); Install 2nd & 3rd RI Feedthroughs (done); Install remaining RI Feedthroughs (done); Final 2nd & 3rd RI Box Assemblys (done); Final remaining RI Box Assemblys (done); Mount remaining RI Boxes to Strongbacks (done); Transport remaining RI boxes & strngbks to ISU (done); Pre-assemble remaining RIII Boxes (done); Final assembly of 2nd RIII endplates/frames (done); Final assembly of 3rd RIII endplates/frames (done); Final assembly of 4th RIII endplates/frames (done); Final assembly of 5th RIII endplates/frames (done); Final assembly of 6th RIII endplates/frames (done); Install 2nd RIII Feedthroughs (done); Install 3rd RIII Feedthroughs (done); Install 4th RIII Feedthroughs (done); Install 5th RIII Feedthroughs (done); Install 6th RIII Feedthroughs (done); Final RIII 2nd Box Assemblys (done); Final RIII 3rd Box Assemblys (done); Final RIII 4th Box Assemblys (done); Final RIII 5th Box Assemblys (done); Final RIII 6th Box Assemblys (done); Mount RIII Boxes to Strongbacks (done)
- 142213133a: Steps: Pre-assemble remaining RII endplate assemblies (done); Pre-assemble remaining RII Boxes (done); Final assembly of 4th RII endplates/frames (done); Final assembly of 5th RII endplates/frames (done); Final assembly of 6th RII endplates/frames (done); Ship RII enplate assys, box parts & strngbks to ODU (done); Inventory, Clean and Kit all RIII DC Hardware (done); Pre-assemble 1st RIII Box (done); Measure critical RIII dimensions on 1st box (done); Revise RIII DC drawings as necessary (done); Final assembly of 1st RIII endplates/frames (done); Install 1st RIII Feedthroughs (done); Final RIII 1st Box Assembly (done); Assemble RIII Strongbacks and Links (done); Mount 1st RIII Box to Strongback (done); Pre-assemble remaining RI Boxes (done); Final assembly of 2nd & 3rd RI endplates/frames (done); Final assembly of remaining RI endplates/frames (done); Install 2nd & 3rd RI Feedthroughs (done); Install remaining RI Feedthroughs (done); Final 2nd & 3rd RI Box Assemblys (done); Final remaining RI Box Assemblys (done); Mount remaining RI Boxes to Strongbacks (done); Transport remaining RI boxes & strngbks to ISU (done); Pre-assemble remaining RIII Boxes (done); Final assembly of 2nd RIII endplates/frames (done); Final assembly of 3rd RIII endplates/frames (done); Final assembly of 4th RIII endplates/frames (done); Final assembly of 5th RIII endplates/frames (done); Final assembly of 6th RIII endplates/frames (done); Install 2nd RIII Feedthroughs (done); Install 3rd RIII Feedthroughs (done); Install 4th RIII Feedthroughs (done); Install 5th RIII Feedthroughs (done); Install 6th RIII Feedthroughs (done); Final RIII 2nd Box Assemblys (done); Final RIII 3rd Box Assemblys (done); Final RIII 4th Box Assemblys (done); Final RIII 5th Box Assemblys (done); Final RIII 6th Box Assemblys (done); Mount RIII Boxes to Strongbacks (done)
- 142213133b: Steps: Pre-assemble remaining RII endplate assemblies (done); Pre-assemble remaining RII Boxes (done); Final assembly of 4th RII endplates/frames (done); Final assembly of 5th RII endplates/frames (done); Final assembly of 6th RII endplates/frames (done); Ship RII enplate assys, box parts & strngbks to ODU (done); Inventory, Clean and Kit all RIII DC Hardware (done); Pre-assemble 1st RIII Box (done); Measure critical RIII dimensions on 1st box (done); Revise RIII DC drawings as necessary (done); Final assembly of 1st RIII endplates/frames (done); Install 1st RIII Feedthroughs (done); Final RIII 1st Box Assembly (done); Assemble RIII Strongbacks and Links (done); Mount 1st RIII Box to Strongback (done); Pre-assemble remaining RI Boxes (done); Final assembly of 2nd & 3rd RI endplates/frames (done); Final assembly of remaining RI endplates/frames (done); Install 2nd & 3rd RI Feedthroughs (done); Install remaining RI Feedthroughs (done); Final 2nd & 3rd RI Box Assemblys (done); Final remaining RI Box Assemblys (done); Mount remaining RI Boxes to Strongbacks (done); Transport remaining RI boxes & strngbks to ISU (done); Pre-assemble remaining RIII Boxes (done); Final assembly of 2nd RIII endplates/frames (done); Final assembly of 3rd RIII endplates/frames (done); Final assembly of 4th RIII endplates/frames (done); Final assembly of 5th RIII endplates/frames (done); Final assembly of 6th RIII endplates/frames (done); Install 2nd RIII Feedthroughs (done); Install 3rd RIII Feedthroughs (done); Install 4th RIII Feedthroughs (done); Install 5th RIII Feedthroughs (done); Install 6th RIII Feedthroughs (done); Final RIII 2nd Box Assemblys (done); Final RIII 3rd Box Assemblys (done); Final RIII 4th Box Assemblys (done); Final RIII 5th Box Assemblys (done); Final RIII 6th Box Assemblys (done); Mount RIII Boxes to Strongbacks (done)

| ID | Activity | Type | Duration | Start | Finish | Predecessors | Complete | Remaining | Planned start | Planned finish | Total float | Free float | Calendar | Resources | Cost | Actual cost | Remaining Material Cost Based on % Compl | Claimed Material Cost Based on % Complet | Initial Claimed Material Calc | Claimed Material Divider | Calculated Remaining Total Cost | MONTHLY EV COST | RESP - Responsibility | STRT%COMP for CM EVM | FNSH%COMP for CM EVM | EVMS Reporting Codes | CAM RESPONSIBLE | CR 09-026 | CR 10-015 | Phil Dev | CR 11-010 | CR 11-026 | CR 11-035 | OPC Allison | CR 11-031 | MARCH!!! | Activities with Steps | CR 11-027 | CR 12-053 | Advance Purchase Plan > 500K | CR 08-043 | CR 12-007 | CR 09-012 | CR 12-001 | CR 12-027 | ReBaseline Actuals Adjustment | Original Activity ID Rebaseline | PRIOR MONTH EV COST | CR 13-002 | BOE Procurement | CR 13-015 | Post Rebaseline | Obligated Prior to Rebaseline | Pre Rebaseline Remaining Budget | CR 11-038 | BOE Labor | Previously In Progress | CR 14-001 | CR 13-010 |
| --- | --- | --- | --- | --- | --- | --- | --- | --- | --- | --- | --- | --- | --- | --- | --- | --- | --- | --- | --- | --- | --- | --- | --- | --- | --- | --- | --- | --- | --- | --- | --- | --- | --- | --- | --- | --- | --- | --- | --- | --- | --- | --- | --- | --- | --- | --- | --- | --- | --- | --- | --- | --- | --- | --- | --- | --- | --- | --- | --- |
| 142213065 | ODU Contract Peg Point #6 String and Test all wires on RII chamber #4 |  | 214d | 2011-10-03 A | 2012-08-13 A | 142213064 FS-60d | 100% |  |  |  |  |  |  | PROCUREMENT<$50K 60 NO ESCALATION; PROCUREMENT>$50K 69 NO ESCALATION | 69,389.79 |  | 0 | 69389.79 | 6938979 | 100 | 0 | 69389.79 | ELOUADRHIRI L | 1 | 1 | D | LATIFA E | 09-026 | 10-015 | MP | 11-010 | 11-026 | 11 -035 |  |  |  |  |  |  |  |  |  |  |  |  |  |  |  |  |  |  |  |  |  |  |  |  |  |  |
| 142213066 | ODU Contract Peg Point #7 String and Test all wires on RII chamber #5 |  | 237d | 2011-11-01 A | 2012-10-15 A | 142213065 FS-165d | 100% |  |  |  |  |  |  | PROCUREMENT>$50K 69 NO ESCALATION | 61,371.95 |  | 0 | 61371.95 | 6137195 | 100 | 0 | 61371.95 | ELOUADRHIRI L | 1 | 1 | D | LATIFA E |  |  | MP | 11-010 | 11-026 | 11 -035 | OPC A |  |  |  |  |  |  |  |  |  |  |  |  |  |  |  |  |  |  |  |  |  |  |  |  |  |
| 142213087 | ISU Contract Phase 2 - Install, tension, string wires and test chamber 3 |  | 306d | 2011-11-01 A | 2013-02-21 A | 142213085 FS-85d | 100% |  | 2011-11-01 | 2013-01-31 |  |  |  | PROCUREMENT<$50K 60 NO ESCALATION; PROCUREMENT>$50K 69 NO ESCALATION | 72,001 |  | 0 | 72001 | 7200100 | 100 | 0 | 72001 | ELOUADRHIRI L | 1 | 1 | D | LATIFA E | 09-026 | 10-015 | MP |  | 11-026 | 11 -035 |  | 11-031 | XX |  |  |  |  |  |  |  |  |  |  |  |  |  |  |  |  |  |  |  |  |  |  |  |
| 142213089 | ISU Contract Phase 3 - Install, tension, string wires and test chamber 4 |  | 346d | 2011-11-01 A | 2013-08-30 A | 142213087 FS-171d | 100% |  | 2011-11-01 | 2013-03-29 |  |  |  | PROCUREMENT>$50K 69 NO ESCALATION | 133,386 |  | 0 | 133386 | 13338600 | 100 | 16673.25 | 133386 | ELOUADRHIRI L | 1 | 1 | D | LATIFA E | 09-026 | 10-015 | MP |  | 11-026 | 11 -035 |  | 11-031 |  |  |  |  |  |  |  |  |  |  |  |  |  |  |  |  |  |  |  |  |  |  |  |  |
| 142213090 | ISU Contract Phase 4a - Install and tension chamber 5 |  | 432d | 2011-11-01 A | 2013-02-04 A | 142213089 FS-195d | 100% |  | 2011-11-01 | 2013-07-31 |  |  |  | PROCUREMENT<$50K 60 NO ESCALATION | 30,000 |  | 0 | 30000 | 3000000 | 100 | 0 | 30000 | ELOUADRHIRI L | 1 | 1 | D | LATIFA E | 09-026 | 10-015 | MP |  | 11-026 | 11 -035 |  | 11-031 | XX |  |  |  |  |  |  |  |  |  |  |  |  |  |  |  |  |  |  |  |  |  |  |  |
| 142213095 | ISU Contract Phase 5a - Install and tension chamber 6 |  | 371d | 2011-11-01 A | 2013-02-12 A | 142213092 FS-285d | 100% |  | 2011-11-01 | 2013-05-03 |  |  |  | PROCUREMENT<$50K 60 NO ESCALATION; PROCUREMENT>$50K 69 NO ESCALATION | 33,346 |  | 0 | 33346 | 3334600 | 100 | 0 | 33346 | ELOUADRHIRI L | 1 | 1 | D | LATIFA E | 09-026 | 10-015 | MP |  | 11-026 | 11 -035 |  | 11-031 |  |  |  |  |  |  |  |  |  |  |  |  |  |  |  |  |  |  |  |  |  |  |  |  |
| 142213232 | P-#3 Build Boxes and Associated Hardware FY12 |  | 573d | 2011-11-01 A | 2013-08-30 A | 9-120M, 142213217P FS-100d, 142213220P FS-60d | 100% |  | 2011-11-01 | 2014-02-28 |  |  |  | MECH ENG [69.42 h]; MECH TECH [104.61 h]; SCIENTIST [29.06 h]; MECH DES [25.83 h] | 13,133.41 | 13,205.58 |  |  |  |  | 3768.23168665 | 12812.7565 | ELOUADRHIRI L | 1 | 1 | S | LATIFA E | 09-026 | 10-015 |  |  | 11-026 | 11 -035 | OPC A |  |  | ST | 11-027 | 12-053 |  |  |  |  |  |  |  |  |  |  |  |  |  |  |  |  |  |  |  |  |
| 142213232a | P-#3 Build Boxes and Associated Hardware FY13 |  | 573d | 2011-11-01 A | 2013-08-30 A | 142213232 FS-350d | 100% |  | 2011-11-01 | 2014-02-28 |  |  |  | SCIENTIST [6.94 h]; MECH DES [6.17 h]; MECH ENG [16.58 h]; MECH TECH [24.99 h] | 3,136.98 | 3,118.63 |  |  |  |  | 928.80582713 | 3158.1293 | ELOUADRHIRI L | 1 | 1 | S | LATIFA E | 09-026 | 10-015 |  |  | 11-026 | 11 -035 |  |  |  | ST | 11-027 | 12-053 |  |  |  |  |  |  |  |  |  |  |  |  |  |  |  |  |  |  |  |  |
| 142213330 | P-#4 Proc Circuit Boards LABOR |  | 10d | 2011-11-01 A | 2011-11-14 A | 142213300M | 100% |  |  |  |  |  |  | MECH TECH [1.87 h]; CONTRB UNIV LBR [33.6 h] | 83.1 | 83.1 |  |  |  |  | 0 | 83.1028 | ELOUADRHIRI L | 1 | 1 | H | LATIFA E | 09-026 | 10-015 |  |  | 11-026 | 11 -035 |  |  |  |  |  |  | APP | 08-043 | 12-007 |  |  |  |  |  |  |  |  |  |  |  |  |  |  |  |  |  |
| 142213320 | P-#4 Proc Box Assy. Fixtures LABOR |  | 19d | 2012-01-02 A | 2012-01-30 A | 142213300M | 100% |  | 2012-01-03 | 2012-01-30 |  |  |  | MECH TECH [8 h] | 355.52 | 355.52 |  |  |  |  | 0 | 355.52 | ELOUADRHIRI L | 1 | 1 | H | LATIFA E | 09-026 | 10-015 |  |  | 11-026 | 11 -035 |  |  |  |  | 11-027 |  | APP |  |  |  |  |  |  |  |  |  |  |  |  |  |  |  |  |  |  |  |
| 142213322P | P-#4 Proc Wires, Pins and Feedthroughs |  | 10d | 2012-01-02 A | 2012-01-17 A | 142213300M | 100% |  | 2012-01-03 | 2012-01-17 |  |  |  | PROCUREMENT<$50K 60 | 109.88 |  | 0 | 109.88 | 10988 | 100 | 0 | 109.88 | ELOUADRHIRI L | 1 | 1 | D | LATIFA E | 09-026 | 10-015 |  |  | 11-026 | 11 -035 |  |  |  |  |  |  | APP |  |  |  |  |  |  |  |  |  |  |  |  |  |  |  |  |  |  |  |
| 142213067 | ODU Contract Peg Point #8 String and Test all wires on RII chamber #6 |  | 269d | 2012-01-03 A | 2013-01-30 A | 142213066 FS-325d | 100% |  | 2012-01-03 | 2013-01-31 |  |  |  | PROCUREMENT<$50K 60 NO ESCALATION | 40,914.64 |  | 0 | 40914.64 | 4091464 | 100 | 0 | 40914.64 | ELOUADRHIRI L | 1 | 1 | D | LATIFA E |  |  | MP | 11-010 | 11-026 | 11 -035 | OPC A |  | XX |  |  |  |  |  |  |  |  |  |  |  |  |  |  |  |  |  |  |  |  |  |  |  |
| 142213068 | ODU Contract Peg Point #9 Five RII Chambers fully tested |  | 309d | 2012-01-03 A | 2013-01-30 A | 142213067 FS-250d | 100% |  | 2012-01-03 | 2013-03-29 |  |  |  | PROCUREMENT>$50K 69 NO ESCALATION; PROCUREMENT<$50K 60 NO ESCALATION | 14,784 |  | 0 | 14784 | 1478400 | 100 | 0 | 14784 | ELOUADRHIRI L | 1 | 1 | D | LATIFA E |  |  |  | 11-010 | 11-026 | 11 -035 | OPC A |  |  |  |  |  |  |  |  |  |  |  |  |  |  |  |  |  |  |  |  |  |  |  |  |  |
| 142213069 | ODU Contract Peg Point #10 Ship Final chamber to JLab |  | 331d | 2012-01-03 A | 2013-02-01 A | 142213068 FS-300d | 100% |  | 2012-01-03 | 2013-04-30 |  |  |  |  |  |  |  |  |  |  |  | 0 | ELOUADRHIRI L | 1 | 1 | D | LATIFA E | 09-026 | 10-015 |  | 11-010 | 11-026 | 11 -035 | OPC A |  |  |  |  |  |  |  |  |  |  |  |  |  |  |  |  |  |  |  |  |  |  |  |  |  |
| 142213317 | P-#4 Proc Endplates & Frames LABOR |  | 9d | 2012-01-03 A | 2012-01-16 A | 142213300M | 100% |  | 2012-01-03 | 2012-01-13 |  |  |  | CONTRB UNIV LBR [40 h]; MECH TECH [8 h] | 355.52 | 355.52 |  |  |  |  | 0 | 355.52 | ELOUADRHIRI L | 1 | 1 | H | LATIFA E | 09-026 | 10-015 |  |  | 11-026 | 11 -035 |  |  |  |  |  |  | APP |  |  |  |  |  |  |  |  |  |  |  |  |  |  |  |  |  |  |  |
| 142213320P | P-#4 Proc Box Assy. Fixtures |  | 9d | 2012-01-03 A | 2012-01-16 A | 142213300M | 100% |  | 2012-01-03 | 2012-01-13 |  |  |  | PROCUREMENT<$50K 60 | 109.88 |  | 0 | 109.88 | 10988 | 100 | 0 | 109.88 | ELOUADRHIRI L | 1 | 1 | D | LATIFA E | 09-026 | 10-015 |  |  | 11-026 | 11 -035 |  |  |  |  | 11-027 |  | APP |  |  |  |  |  |  |  |  |  |  |  |  |  |  |  |  |  |  |  |
| 142213322 | P-#4 Proc Wires, Pins and Feedthroughs LABOR |  | 15d | 2012-01-03 A | 2012-01-24 A | 142213300M | 100% |  |  |  |  |  |  | MECH TECH [8 h] | 355.52 | 355.52 |  |  |  |  | 0 | 355.52 | ELOUADRHIRI L | 1 | 1 | H | LATIFA E | 09-026 | 10-015 |  |  | 11-026 | 11 -035 |  |  |  |  |  |  | APP |  |  |  |  |  |  |  |  |  |  |  |  |  |  |  |  |  |  |  |
| 142213335 | P-#4 Build Stringing Fixtures, Machines and Platforms |  | 9d | 2012-01-03 A | 2012-01-16 A | 142213300M | 100% |  | 2012-01-03 | 2012-01-13 |  |  |  | MECH TECH [8 h] | 355.52 | 355.52 |  |  |  |  | 0 | 355.51982 | ELOUADRHIRI L | 1 | 1 | H | LATIFA E | 09-026 | 10-015 |  |  | 11-026 | 11 -035 |  |  |  |  |  |  |  | 08-043 |  |  |  |  |  |  |  |  |  |  |  |  |  |  |  |  |  |  |
| 142213144 | P-#2 String Chambers Part B FY11 |  | 69d | 2012-01-09 A | 2012-04-16 A | 142213142 FS-40d | 100% |  |  |  |  |  |  | MECH TECH [524.86 h]; PLABOR | 103,460.26 | 23,324.78 |  |  |  |  | 0 | 102741.2002 | ELOUADRHIRI L | 1 | 1 | S | LATIFA E | 09-026 | 10-015 |  |  | 11-026 | 11 -035 |  |  |  | ST | 11-027 |  |  | 08-043 |  | 09-012 | 12-001 |  |  |  |  |  |  |  |  |  |  |  |  |  |  |  |
| 142213144a | P-#2 String Chambers Part B FY12 |  | 69d | 2012-01-09 A | 2012-04-16 A | 142213144 FS-90d | 100% |  |  |  |  |  |  | MECH TECH [490.1 h]; PLABOR | 98,995.56 | 21,780.04 |  |  |  |  | 0 | 98995.564 | ELOUADRHIRI L | 1 | 1 | S | LATIFA E | 09-026 | 10-015 |  |  | 11-026 | 11 -035 |  |  |  | ST | 11-027 |  |  | 08-043 |  | 09-012 | 12-001 |  |  |  |  |  |  |  |  |  |  |  |  |  |  |  |
| 142213330a | P-#4 Proc Circuit Boards LABOR Revised FY12 |  | 232d | 2012-02-01 A | 2013-01-14 A | 9-120M FS+60d | 100% |  | 2012-02-01 | 2013-01-07 |  |  |  | CONTRB UNIV LBR [110.4 h]; ELEC TECH [1503.2 h] | 66,911.77 | 66,944.35 |  |  |  |  | 0 | 66336.216 | ELOUADRHIRI L | 1 | 1 | S | LATIFA E | 09-026 | 10-015 |  |  | 11-026 | 11 -035 |  |  | XX | ST |  |  | APP | 08-043 | 12-007 |  |  |  |  |  |  |  |  |  |  |  |  |  |  |  |  |  |
| 142213242 | P-#3 String Chambers FY12 |  | 171d | 2012-02-13 A | 2012-10-15 A | 142213222, 142213232a FS-345d, 142213230P FS-160d, 142213235P FS-247d, 142213144a FS-110d, 142213222P, 142213235a FS-275d, 142213230 FS-75d, 9-120M, 142213232 FS-345d | 100% |  | 2012-02-13 | 2012-10-12 |  |  |  | MECH TECH [635.35 h]; PLABOR | 167,441.21 | 28,771.73 |  |  |  |  | 0 | 167388.454 | ELOUADRHIRI L | 1 | 1 | S | LATIFA E | 09-026 | 10-015 |  |  | 11-026 | 11 -035 | OPC A |  |  | ST | 11-027 | 12-053 |  | 08-043 | 12-007 | 09-012 |  |  |  |  |  |  |  |  |  |  |  |  |  |  |  |  |
| 142213242a | P-#3 String Chambers FY13 |  | 172d | 2012-02-13 A | 2012-10-15 A | 142213242 FS-145d | 100% |  |  |  |  |  |  | MECH TECH [817.85 h]; PLABOR | 221,256.67 | 36,419.53 |  |  |  |  | 0 | 222343.741 | ELOUADRHIRI L | 1 | 1 | S | LATIFA E | 09-026 | 10-015 |  |  | 11-026 | 11 -035 |  |  |  | ST | 11-027 | 12-053 |  | 08-043 | 12-007 | 09-012 |  |  |  |  |  |  |  |  |  |  |  |  |  |  |  |  |
| 142213332 | P-#4 Build Boxes and Associated Hardware FY12 |  | 223d | 2012-03-12 A | 2012-12-17 A | 142213317, 142213117B FS-110d, 142213117Bb FS-110d | 100% |  | 2012-03-12 | 2013-02-01 |  |  |  | MECH TECH [7.63 h]; MECH ENG [7.63 h] | 884.23 | 886.03 |  |  |  |  | 0 | 874.0928 | ELOUADRHIRI L | 1 | 1 | S | LATIFA E | 09-026 | 10-015 |  |  | 11-026 | 11 -035 | OPC A |  |  | ST |  | 12-053 |  |  |  |  |  |  |  |  |  |  |  |  |  |  |  |  |  |  |  |  |
| 142213332a | P-#4 Build Boxes and Associated Hardware FY13 |  | 236d | 2012-03-12 A | 2012-12-17 A | 142213332 FS-50d | 100% |  | 2012-03-12 | 2013-02-21 |  |  |  | MECH ENG [0.37 h]; MECH TECH [0.37 h] | 42.92 | 42.76 |  |  |  |  | 0 | 43.7414 | ELOUADRHIRI L | 1 | 1 | S | LATIFA E | 09-026 | 10-015 |  |  | 11-026 | 11 -035 |  |  |  | ST |  | 12-053 |  |  |  |  |  |  |  |  |  |  |  |  |  |  |  |  |  |  |  |  |
| 142213335P | P-#4 Proc Cleanroom Fixtures and Equipment Part A |  | 118d | 2012-04-02 A | 2012-09-17 A | 142213300M FS+20d | 100% |  |  |  |  |  |  | PROCUREMENT<$50K 60 | 23,889.06 |  | 0 | 23889.06 | 2388906 | 100 | 0 | 23889.06 | ELOUADRHIRI L | 1 | 1 | D | LATIFA E | 09-026 | 10-015 |  |  | 11-026 | 11 -035 |  |  |  |  | 11-027 |  |  | 08-043 |  |  |  | 12-027 |  |  |  |  |  |  |  |  |  |  |  |  |  |  |
| 142213330b | P-#4 Proc Circuit Boards LABOR Revised FY13 |  | 127d | 2012-07-02 A | 2013-01-22 A | 142213330a FS-250d | 100% |  | 2012-07-02 | 2013-01-07 |  |  |  | ELEC TECH [903.2 h] | 40,489.96 | 40,536.8 |  |  |  |  | 0 | 37814.5944 | ELOUADRHIRI L | 1 | 1 | S | LATIFA E | 09-026 | 10-015 |  |  | 11-026 | 11 -035 | OPC A |  | XX | ST |  |  | APP | 08-043 | 12-007 |  |  |  |  |  |  |  |  |  |  |  |  |  |  |  |  |  |
| 142213092 | ISU Contract Phase 4b - String wires and test chamber 5 |  | 203d | 2012-10-01 A | 2013-08-30 A | 142213090 FS-165d | 100% |  | 2012-10-01 | 2013-07-26 |  |  |  | PROCUREMENT<$50K 60 NO ESCALATION | 42,001 |  | 0 | 42001 | 4200100 | 100 | 24499.1833 | 42001 | ELOUADRHIRI L | 1 | 1 | D | LATIFA E | 09-026 | 10-015 |  |  | 11-026 | 11 -035 | OPC A | 11-031 |  |  |  |  |  |  |  |  |  |  |  |  |  |  |  |  |  |  |  |  |  |  |  |  |
| 142213097 | ISU Contract Phase 5b - String wires and test chamber 6 |  | 307d | 2012-10-01 A | 2013-08-30 A | 142213095 FS-140d | 100% |  | 2012-10-01 | 2013-12-31 |  |  |  | PROCUREMENT<$50K 60 NO ESCALATION; PROCUREMENT>$50K 69 NO ESCALATION | 100,040 |  | 0 | 100040 | 10004000 | 100 | 58353.332 | 100040 | ELOUADRHIRI L | 1 | 1 | D | LATIFA E | 09-026 | 10-015 |  |  | 11-026 | 11 -035 | OPC A | 11-031 |  |  |  |  |  |  |  |  |  |  |  |  |  |  |  |  |  |  |  |  |  |  |  |  |
| 142213100 | ISU Contract Phase 6 - Ship chambers, fixtures and equipment to JLab |  | 394d | 2012-10-01 A | 2013-08-30 A | 142213097 FS-260d | 100% |  | 2012-10-01 | 2014-05-06 |  |  |  | PROCUREMENT>$50K 69 NO ESCALATION | 27,939 |  | 0 | 27939 | 2793900 | 100 | 27939 | 27939 | ELOUADRHIRI L | 1 | 1 | D | LATIFA E | 09-026 | 10-015 |  |  | 11-026 | 11 -035 |  | 11-031 |  |  |  |  |  |  |  |  |  |  |  |  |  |  |  |  |  |  |  |  |  |  |  |  |
| 142213342 | P-#4 String Chambers |  | 214d | 2012-11-12 A | 2013-08-30 A | 142213132, 142213332a FS-80d, 142213300M, 142213133Ca FS-500d, 142213330PA FS-235d, 9-130M, 142213335P FS-247d, 142213330, 142213330P FS-500d, 142213133 FS-245d, 142213335 FS-247d | 100% |  | 2012-11-12 | 2013-09-24 |  |  |  | PLABOR; MECH TECH [1098.76 h] | 331,945.14 | 50,624.31 |  |  |  |  | 89560.953528 | 331945.1436 | ELOUADRHIRI L | 1 | 1 | S | LATIFA E | 09-026 | 10-015 |  |  | 11-026 | 11 -035 | OPC A |  |  | ST |  |  |  | 08-043 | 12-007 |  |  | 12-027 |  |  |  |  |  |  |  |  |  |  |  |  |  |  |
| 142213330PA | P-#5 Proc LVHV Distribution Cables and Boxes |  | 122d | 2013-01-07 A | 2013-08-30 A | 9-130M, 142213330P FS-250d | 100% |  | 2013-01-07 | 2013-06-28 |  |  |  | PROCUREMENT<$50K 60; PROCUREMENT>$50K 69 | 185,190.91 |  | 0 | 185190.91 | 18519091 | 100 | 92595.455 | 185190.91 | ELOUADRHIRI L | 1 | 1 | S | LATIFA E | 09-026 | 10-015 |  |  | 11-026 | 11 -035 | OPC A |  |  | ST | 11-027 |  | APP | 08-043 |  |  |  | 12-027 |  |  |  |  |  |  |  |  |  |  |  |  |  |  |
| 142213360 | Re-Baseline Actuals Adjustment |  | 1d | 2013-08-30 A | 2013-08-30 A |  | 100% |  | 2013-09-03 | 2013-09-03 |  |  |  | PROCUREMENT>$50K 69 NO ESCALATION | -162,969.92 |  |  |  |  | 100 |  |  |  |  |  |  |  |  |  |  |  |  |  |  |  |  |  |  |  |  |  |  |  |  |  | ADJ |  |  |  |  |  |  |  |  |  |  |  |  |  |
| 242213073 | ODU Contract Mount Electronics on Chambers |  | 267d | 2013-09-03 A | 2014-02-28 | 9-130M FS+228d | 12% | 75d | 2013-10-01 | 2014-10-28 | 749d | 0d | 8/5 M-F w/JLAB Holidays ReBaseline | PROCUREMENT>$50K 69 NO ESCALATION; PROCUREMENT<$50K 60 NO ESCALATION | 122,486.85 |  | 107788.428 | 14698.422 | 1469842.2 | 100 |  | 7349.211 | ELOUADRHIRI L | 1 | 1 | D | LATIFA E |  |  |  | 11-010 | 11-026 | 11 -035 |  |  |  |  |  |  |  |  |  |  |  |  |  | 242213073 | 7349.211 | 13-002F | OB | 13-015 | PR | OB |  |  |  |  |  |  |
| 242213092 | ISU Contract Phase 4b - String wires and test chamber 5 |  | 98d | 2013-09-03 A | 2014-01-31 | 9-130M FS+228d | 25% | 55d | 2013-10-01 | 2014-02-28 | 470d | 43d | 8/5 M-F w/JLAB Holidays ReBaseline | PROCUREMENT<$50K 60 NO ESCALATION | 16,334.19 |  | 12250.6425 | 4083.5475 | 408354.75 | 100 |  | 2041.77375 | ELOUADRHIRI L | 1 | 1 | D | LATIFA E | 09-026 | 10-015 |  |  | 11-026 | 11 -035 |  | 11-031 |  |  |  |  |  |  |  |  |  |  |  | 242213092 | 2041.77375 | 13-002F | OB | 13-015 | PR | OB |  |  |  |  |  |  |
| 242213097 | ISU Contract Phase 5b - String wires and test chamber 6 |  | 98d | 2013-09-03 A | 2014-01-31 | 242213092 FS-98d | 25% | 55d | 2013-10-01 | 2014-02-28 | 427d | 43d | 8/5 M-F w/JLAB Holidays ReBaseline | PROCUREMENT<$50K 60 NO ESCALATION; PROCUREMENT>$50K 69 NO ESCALATION | 38,905.56 |  | 29179.17 | 9726.39 | 972639 | 100 |  | 4863.195 | ELOUADRHIRI L | 1 | 1 | D | LATIFA E | 09-026 | 10-015 |  |  | 11-026 | 11 -035 |  | 11-031 |  |  |  |  |  |  |  |  |  |  |  | 242213097 | 4863.195 | 13-002F | OB | 13-015 | PR | OB |  |  |  |  |  |  |
| 242213100 | ISU Contract Phase 6 - Ship chambers, fixtures and equipment to JLab |  | 161d | 2013-09-03 A | 2014-04-30 | 242213097 FS-98d |  | 118d | 2013-10-01 | 2014-05-29 | 384d | 0d | 8/5 M-F w/JLAB Holidays ReBaseline | PROCUREMENT>$50K 69 NO ESCALATION | 88,172.38 |  | 88172.38 | 0 | 0 | 100 |  | 0 | ELOUADRHIRI L | 1 | 1 | D | LATIFA E | 09-026 | 10-015 |  |  | 11-026 | 11 -035 |  | 11-031 |  |  |  |  |  |  |  |  |  |  |  | 242213100 |  | 13-002F | OB | 13-015 | PR | OB |  |  |  |  |  |  |
| 242213133C | P-#2 Build Boxes and Associated Hardware FY13 |  | 20d | 2013-09-03 A | 2014-05-29 | 9-130M FS+228d | 50% | 138d | 2013-10-01 | 2013-10-28 | 695d | 22d | 8/5 M-F w/JLAB Holidays ReBaseline | MECH TECH [1.52 h] | 71.93 | 16.84 |  |  |  |  |  | 0 | ELOUADRHIRI L | 1 | 1 | H | LATIFA E | 09-026 | 10-015 |  |  | 11-026 | 11 -035 |  |  |  |  | 11-027 | 12-053 |  | 08-043 |  |  |  |  |  | 242213133C | 34.8536 | 13-002F |  | 13-015 | PR |  | 19225.54 | 11-038 | PE | Review |  |  |
| 242213133Ca | P-#2 Build Boxes and Associated Hardware FY14 |  | 161d | 2013-09-03 A | 2014-05-28 | 242213133C FS-160d | 50% | 137d | 2013-10-01 | 2014-05-29 | 696d | 152d | 8/5 M-F w/JLAB Holidays ReBaseline | MECH TECH [12.26 h] | 580.14 | 136.6 |  |  |  |  |  | 0 | ELOUADRHIRI L | 1 | 1 | H | LATIFA E | 09-026 | 10-015 |  |  | 11-026 | 11 -035 |  |  |  |  | 11-027 | 12-053 |  | 08-043 |  |  |  |  |  | 242213133C | 290.0716 | 13-002F |  | 13-015 | PR |  | 19225.54 | 11-038 | PE | Review | 14-001 |  |
| 242213232 | P-#3 Build Boxes and Associated Hardware FY13 |  | 141d | 2013-09-03 A | 2014-04-02 | 9-130M FS+228d | 50% | 98d | 2013-10-01 | 2014-04-30 | 726d | 22d | 8/5 M-F w/JLAB Holidays ReBaseline | MECH TECH [1.86 h] | 88.02 | 26.46 |  |  |  |  |  | 0 | ELOUADRHIRI L | 1 | 1 | H | LATIFA E | 09-026 | 10-015 |  |  | 11-026 | 11 -035 |  |  |  |  | 11-027 | 12-053 |  |  |  |  |  |  |  | 242213232 | 42.6498 | 13-002F |  | 13-015 | PR |  | 7506.32 |  | PE | Review |  |  |
| 242213232a | P-#3 Build Boxes and Associated Hardware FY14 |  | 121d | 2013-09-03 A | 2014-04-01 | 242213232 FS-120d | 50% | 97d | 2013-10-01 | 2014-04-02 | 727d | 247d | 8/5 M-F w/JLAB Holidays ReBaseline | MECH TECH [11.28 h] | 533.77 | 161.59 |  |  |  |  |  | 0 | ELOUADRHIRI L | 1 | 1 | H | LATIFA E | 09-026 | 10-015 |  |  | 11-026 | 11 -035 |  |  |  |  | 11-027 | 12-053 |  |  |  |  |  |  |  | 242213232 | 266.8848 | 13-002F |  | 13-015 | PR |  | 7506.32 |  | PE | Review | 14-001 |  |
| 242213330PA | Proc LVHV Distribution Cables and Boxes |  | 387d | 2013-09-03 A | 2015-04-01 | 9-130M FS+228d | 25% | 344d | 2013-10-01 | 2015-04-29 | 480d | 0d | 8/5 M-F w/JLAB Holidays ReBaseline | PROCUREMENT<$50K 60 NO ESCALATION FY14; PROCUREMENT>$50K 69 NO ESCALATION FY14 | 65,000 |  | 48750 | 16250 | 1625000 | 100 |  | 9750 | ELOUADRHIRI L | 1 | 1 | D | LATIFA E | 09-026 | 10-015 |  |  | 11-026 | 11 -035 |  |  |  |  | 11-027 |  | APP | 08-043 |  |  |  | 12-027 |  | 242213330PA | 6500 | 13-002F | EJ | 13-015 | PR | OB-2 |  |  |  |  |  |  |
| 242213331 | HV Dist Box Construction and Testing Labor |  | 387d | 2013-09-03 A | 2015-04-01 | 9-130M FS+228d | 50% | 344d | 2013-10-01 | 2015-04-29 | 480d | 0d | 8/5 M-F w/JLAB Holidays ReBaseline | PROCUREMENT<$50K 60 NO ESCALATION FY14 | 3,900 |  | 1950 | 1950 | 195000 | 100 |  | 1482 | ELOUADRHIRI L | 1 | 1 | U | LATIFA E | 09-026 | 10-015 |  |  | 11-026 | 11 -035 |  |  |  |  | 11-027 |  | APP | 08-043 |  |  |  |  |  | 242213331 | 468 | 13-002F | EJ | 13-015 | PR | OB-2 |  |  |  |  |  |  |
| 242213335Pa | P-#4 Proc Cleanroom Fixtures and Equipment Part B |  | 19d | 2013-09-03 A | 2013-09-24 A | 9-130M FS+228d | 100% |  | 2013-10-01 | 2013-10-25 |  |  | 8/5 M-F w/JLAB Holidays ReBaseline | PROCUREMENT<$50K 60; PROCUREMENT>$50K 69 | 197.28 |  | 0 | 197.28 | 19728 | 100 |  | 0 | ELOUADRHIRI L | 1 | 1 | D | LATIFA E | 09-026 | 10-015 |  |  | 11-026 | 11 -035 |  |  |  |  | 11-027 |  |  | 08-043 |  |  |  | 12-027 |  | 242213335Pa | 197.28 | 13-002F | OB | 13-015 | PR | OB |  |  |  |  |  |  |
| 242213342 | P-#4 String Chambers FY13 |  | 81d | 2013-09-03 A | 2013-09-23 A | 9-130M FS+228d, 242213133Ca FS-289d, 242213133C FS-289d, 242213335Pa FS-247d | 100% |  | 2013-10-01 | 2014-02-05 |  |  | 8/5 M-F w/JLAB Holidays ReBaseline | ELEC TECH [15.41 h]; MECH TECH [30.81 h] | 2,182.05 | 2,114.72 |  |  |  |  |  | 0 | ELOUADRHIRI L | 1 | 1 | U | LATIFA E | 09-026 | 10-015 |  |  | 11-026 | 11 -035 |  |  |  |  |  |  |  | 08-043 | 12-007 | 09-012 |  | 12-027 |  | 242213342 | 2114.719066 | 13-002F |  | 13-015 | PR |  | 403463.31 |  | PE | Review |  |  |
| 242213342a | P-#4 String Chambers FY14 |  | 61d | 2013-09-03 A | 2013-09-23 A | 242213133Ca FS-289d, 242213342 | 100% |  | 2013-10-01 | 2014-01-07 |  |  | 8/5 M-F w/JLAB Holidays ReBaseline | ELEC TECH [46.99 h]; MECH TECH [93.99 h] | 6,655.67 | 6,450.31 |  |  |  |  |  | 0 | ELOUADRHIRI L | 1 | 1 | U | LATIFA E | 09-026 | 10-015 |  |  | 11-026 | 11 -035 |  |  |  |  |  |  |  | 08-043 | 12-007 | 09-012 |  | 12-027 |  | 242213342 | 6655.6658 | 13-002F |  | 13-015 | PR |  | 403463.31 |  | PE | Review | 14-001 |  |
| 242213347 | P-#5 String Chambers |  | 242d | 2013-09-03 A | 2014-12-19 | 242213342, 242213342a | 24% | 280d | 2014-01-08 | 2014-12-19 | 544d | 64d | 8/5 M-F w/JLAB Holidays ReBaseline | ELEC TECH [1827.9 h]; MECH TECH [2741.86 h] | 215,637.84 | 28,295.21 |  |  |  |  |  | 14016.4592672 | ELOUADRHIRI L | 1 | 1 | S | LATIFA E | 09-026 | 10-015 |  |  | 11-026 | 11 -035 |  |  |  | ST | 11-027 |  |  | 08-043 |  | 09-012 |  | 12-027 |  | 242213347 | 37520.98326912 | 13-002F | PE | 13-015 | PR |  |  |  | PE |  | 14-001 | 13-010 |
| 242213078 | De-Obligation of ODU Contract |  | 1d | 2013-10-01 A | 2014-02-28 | 242213073 FS-75d | 56% | 75d | 2014-02-28 | 2014-02-28 | 749d | 269d | 8/5 M-F w/JLAB Holidays ReBaseline | PROCUREMENT>$50K 69 NO ESCALATION; PROCUREMENT<$50K 60 NO ESCALATION | -47,486.85 |  | -21084.1614 | -26402.6886 | -2640268.86 | 100 |  | 0 | ELOUADRHIRI L | 1 | 1 | D | LATIFA E |  |  |  | 11-010 | 11-026 | 11 -035 |  |  |  | NB |  |  |  |  |  |  |  |  |  | 242213073 |  | 13-002F | OB | 13-015 | PR | OB-2 |  |  |  |  |  |  |
| 242213355M | Chambers Complete | milestone | 0d | 2015-04-01 | 2015-04-01 | 242213331, 242213232a, 242213100, 242213330PA, 242213342, 242213073, 242213078, 242213342a, 242213232, 242213347 |  |  |  |  | 480d | 0d | 8/5 M-F w/JLAB Holidays ReBaseline |  |  |  |  |  |  |  |  | 0 | ELOUADRHIRI L | 1 | 1 | M | LATIFA E | 09-026 | 10-015 |  |  | 11-026 | 11 -035 |  |  |  |  |  |  |  |  |  |  |  | 12-027 |  | 242213355M |  | 13-002F |  | 13-015 | PR |  |  |  |  |  |  |  |

Notes:
- 142213232: Steps: Pre-assemble any remaining RI Boxes (done); Final assembly of any remaining RI endplates/frames (done); Install any remaining RI Feedthroughs (done); Final any remaining RI Box Assemblies (done); Mount any remaining RI Boxes to Strongbacks (done); Transport any remaining RI boxes & strngbks to ISU (done); Pre-assemble any remaining RIII Boxes (done); Final assembly of any remaining RIII endplates/frames (done); Install any remaining RIII Feedthroughs (done); Final RIII any remaining Box Assemblies (done); Mount any remaining RIII Boxes to Strongbacks (done)
- 142213232a: Steps: Pre-assemble any remaining RI Boxes (done); Final assembly of any remaining RI endplates/frames (done); Install any remaining RI Feedthroughs (done); Final any remaining RI Box Assemblies (done); Mount any remaining RI Boxes to Strongbacks (done); Transport any remaining RI boxes & strngbks to ISU (done); Pre-assemble any remaining RIII Boxes (done); Final assembly of any remaining RIII endplates/frames (done); Install any remaining RIII Feedthroughs (done); Final RIII any remaining Box Assemblies (done); Mount any remaining RIII Boxes to Strongbacks (done)
- 142213144: Steps: Install 1st RIII chamber on stringing fixture (done); Install 1st RIII pre-tension harware (done); Stringing Field wires of 1st region 3 (done); Stringing Guard wires of 1st region 3 (done)
- 142213144a: Steps: Install 1st RIII chamber on stringing fixture (done); Install 1st RIII pre-tension harware (done); Stringing Field wires of 1st region 3 (done); Stringing Guard wires of 1st region 3 (done)
- 142213330a: Steps: STB - Receive approved RIII end plate files from ME group (done); STB - copy and verify RIII schematics (done); STB - RIII component placement and optimization (done); STB - RIII board layout (multilayer) & design rule check (done); STB - Create RIII manufacturing files (done); STB - order all RIII components (done); STB - Receive RIII bare boards and send for solder/assembly (done); STB - Receive RIII assembled boards and bench test (done); STB - RIII STBs ready to be installed on drift chamber (done); HVB - copy and verify RIII schematics (done); HVB - RIII component placement and optimization (done); HVB - RIII board layout (2-layer) & design rule check (done); HVB - Create RIII manufacturing files (done); HVB - order all RIII components (done); HVB - Receive RIII bare boards and send for solder/assembly (done); HVB - Receive RIII assembled boards and HiPot bench test (done); HVB - RIII HVBs ready to be installed on drift chamber (done)
- 142213242: Steps: String and test all SL5 field wires on 1st RIII chamber (done); String and test all SL5 sense wires on 1st RIII chamber (done); String and test all SL6 sense wires on 1st RIII chamber (done); Hire and train last 2 RIII stringers (done); Re- Test all wires on 1st RIII chamber (done); Pot crimp pins on 1st RIII chamber (done); Survey and fiducialize 1st RIII chamber (done); Install gas window, Instrument 1st RIII Chamber (done); Install 2nd RIII chamber on stringing fixture (done); Install 2nd RIII pre-tension harware (done); String and test all SL6 field wires on 2nd RIII chamber (done); String and test all SL5 field wires on 2nd RIII chamber (done); String and test all SL5 sense wires on 2nd RIII chamber (done); String and test all SL6 sense wires on 2nd RIII chamber (done); Re-Test all wires on 2nd RII chamber (done); Pot crimp pins on 2nd RIII chamber (done); Survey and fiducialize 2nd RIII chamber (done); Install gas window, Instrument 2nd RIII Chamber (done); Install 3rd RIII chamber on stringing fixture (done); Install 3rd RIII pre-tension harware (done)
- 142213242a: Steps: String and test all SL5 field wires on 1st RIII chamber (done); String and test all SL5 sense wires on 1st RIII chamber (done); String and test all SL6 sense wires on 1st RIII chamber (done); Hire and train last 2 RIII stringers (done); Re- Test all wires on 1st RIII chamber (done); Pot crimp pins on 1st RIII chamber (done); Survey and fiducialize 1st RIII chamber (done); Install gas window, Instrument 1st RIII Chamber (done); Install 2nd RIII chamber on stringing fixture (done); Install 2nd RIII pre-tension harware (done); String and test all SL6 field wires on 2nd RIII chamber (done); String and test all SL5 field wires on 2nd RIII chamber (done); String and test all SL5 sense wires on 2nd RIII chamber (done); String and test all SL6 sense wires on 2nd RIII chamber (done); Re-Test all wires on 2nd RII chamber (done); Pot crimp pins on 2nd RIII chamber (done); Survey and fiducialize 2nd RIII chamber (done); Install gas window, Instrument 2nd RIII Chamber (done); Install 3rd RIII chamber on stringing fixture (done); Install 3rd RIII pre-tension harware (done)
- 142213332: Steps: Transport strung RI chambers from ISU to Jlab (done); Transport completed R2 box assemblies from ODU to Jlab (done)
- 142213332a: Steps: Transport strung RI chambers from ISU to Jlab (done); Transport completed R2 box assemblies from ODU to Jlab (done)
- 142213330b: Steps: STB - Receive approved RIII end plate files from ME group (done); STB - copy and verify RIII schematics (done); STB - RIII component placement and optimization (done); STB - RIII board layout (multilayer) & design rule check (done); STB - Create RIII manufacturing files (done); STB - order all RIII components (done); STB - Receive RIII bare boards and send for solder/assembly (done); STB - Receive RIII assembled boards and bench test (done); STB - RIII STBs ready to be installed on drift chamber (done); HVB - copy and verify RIII schematics (done); HVB - RIII component placement and optimization (done); HVB - RIII board layout (2-layer) & design rule check (done); HVB - Create RIII manufacturing files (done); HVB - order all RIII components (done); HVB - Receive RIII bare boards and send for solder/assembly (done); HVB - Receive RIII assembled boards and HiPot bench test (done); HVB - RIII HVBs ready to be installed on drift chamber (done)
- 142213342: Steps: String and test all SL6 field wires on 3rd RIII chamber (done); String and test all SL5 field wires on 3rd RIII chamber (done); String and test all SL5 sense wires on 3rd RIII chamber (done); String and test all SL6 sense wires on 3rd RIII chamber (done); Re-Test all wires on 3rd RIII chamber (done); Pot crimp pins on 3rd RIII chamber (done); Survey and fiducialize 3rd RIII chamber (done); Install gas window, Instrument 3rd RIII Chamber (done); Install 4th RIII pre-tension harware (done); Install 4th RIII chamber on stringing fixture (done); String and test all SL6 field wires on 4th RIII chamber (done); String and test all SL5 field wires on 4th RIII chamber (done); String and test all SL5 sense wires on 4th RIII chamber (done); String and test all SL6 sense wires on 4th RIII chamber (done); Test all wires on 4th RIII chamber (done); Pot crimp pins on 4th RIII chamber (done); Instrument RI chambers (done); Survey and fiducialize 4th RIII chamber (done); Install gas window, Instrument 4th RIII Chamber (done); Install 5th RIII chamber on stringing fixture (done); Install 5th RIII pre-tension harware (done)
- 142213330PA: Steps: 1/2 Hardware/Electronics for upgrades???? (done); LV distribution boxes (done); LV cables and connectors (done); Hv distribution boxes (done)
- 242213092: Explanation: Intentional Linear Curve
- 242213097: Explanation: Intentional Linear Curve
- 242213347: Steps: String and test all SL5 sense wires on 5th RIII chamber (done); String and test all SL6 sense wires on 5th RIII chamber (done); Re-Test all wires on 5th RIII chamber (done); Pot crimp pins on 5th RIII chamber (done); Survey and fiducialize 5th RIII chamber (done); Install gas window, Instrument 5th RIII Chamber (done); Install 6th RIII chamber on stringing fixture; Install 6th RIII pre-tension harware; String and test all SL6 field wires on 6th RIII chamber; String and test all SL5 field wires on 6th RIII chamber; String and test all SL5 sense wires on 6th RIII chamber; String and test all SL6 sense wires on 6th RIII chamber; Re-Test all wires on 6th RIII chamber; Pot crimp pins on 6th RIII chamber; Survey and fiducialize 6th RIII chamber; Install gas window, Instrument 6th RIII Chamber; Survey/fiducialize all RI chambers????????; transport RI chambers to hall; finish any remaining chamber stringing tasks; transport RII chambers to hall; test RII chambers; Install RII chambers; test RI chambers; Install RI chambers; transport RIII chambers to hall; test RIII chambers; Install RIII chambers
- 242213078: Explanation: EVMS Code of D ....Partially / deobligated in October with more to follow per Latifa. PMK 11/7/13

| ID | WBS | Activity | Type | Duration | Start | Finish | Predecessors | Complete | Planned start | Planned finish | Resources | Cost | Actual cost | MONTHLY EV COST | RESP - Responsibility | STRT%COMP for CM EVM | FNSH%COMP for CM EVM | Milestone Level | EVMS Reporting Codes | CAM RESPONSIBLE | CR 10-014 | CR 11-026 | CR 11-035 | Calculated Remaining Total Cost | Advance Purchase Plan > 500K | CR 10-011 | Remaining Material Cost Based on % Compl | Claimed Material Cost Based on % Complet | Initial Claimed Material Calc | Claimed Material Divider | CR 12-007 | CR 12-054 | CR 10-060 | CR 11-001 | OPC Allison |
| --- | --- | --- | --- | --- | --- | --- | --- | --- | --- | --- | --- | --- | --- | --- | --- | --- | --- | --- | --- | --- | --- | --- | --- | --- | --- | --- | --- | --- | --- | --- | --- | --- | --- | --- | --- |
|  | 2 | **1.4.2.2.2 CALORIMETRY** |  |  | 2009-08-03 | 2014-11-03 |  |  |  |  |  |  |  |  |  |  |  |  |  |  |  |  |  |  |  |  |  |  |  |  |  |  |  |  |  |
|  | 1 | **1.4.2.2.2.1 CENTRAL CALORIMETER** |  |  |  |  |  |  |  |  |  |  |  |  |  |  |  |  |  |  |  |  |  |  |  |  |  |  |  |  |  |  |  |  |  |
|  | 2 | **1.4.2.2.2.2 COIL CALORIMETER** |  |  |  |  |  |  |  |  |  |  |  |  |  |  |  |  |  |  |  |  |  |  |  |  |  |  |  |  |  |  |  |  |  |
|  | 3 | **1.4.2.2.2.3 FORWARD CALORIMETER** |  |  | 2009-08-03 | 2014-11-03 |  |  |  |  |  |  |  |  |  |  |  |  |  |  |  |  |  |  |  |  |  |  |  |  |  |  |  |  |  |
| 142223000M |  | EC-P-#1 Constr Start (FWD CAL) | milestone | 0d | 2009-08-03 A | 2009-08-03 A | 9-100M, 1222223041M, 1222223040 | 100% | 2009-10-01 | 2009-10-01 |  |  |  | 0 | ELOUADRHIRI L | 1 | 1 | 6 | M | LATIFA E | 10-014 | 11-026 | 11 -035 |  |  |  |  |  |  |  |  |  |  |  |  |
| 142223015 |  | EC-P-#1 Prcrmnt Prep for PMTs (FWD CAL) |  | 3d | 2009-08-03 A | 2009-08-05 A | 142223000M | 100% |  |  |  |  |  | 0 | ELOUADRHIRI L | 1 | 1 |  | Z | LATIFA E | 10-014 | 11-026 | 11 -035 |  |  |  |  |  |  |  |  |  |  |  |  |
| 142223017 |  | EC-P-#1 Vend Fab of PMTs (FWD CAL) |  | 20d | 2009-08-03 A | 2009-08-28 A | 9-100M FS+60d, 142223015 | 100% |  |  | SCIENTIST [100 h]; ELEC TECH [320 h]; MECH DES [40 h]; MECH ENG [40 h]; MECH TECH [40 h] | 25,204.4 | 25,204.4 | 26008.2 | ELOUADRHIRI L | 1 | 1 |  | P | LATIFA E | 10-014 | 11-026 | 11 -035 | 0 | APP | 10-011 |  |  |  |  |  |  |  |  |  |
| 142223005 |  | EC-P-#1 Prcrmnt Prep for Assy box (FWD CAL) |  | 114d | 2009-09-07 A | 2010-02-26 A | 142223000M | 100% | 2009-09-08 | 2010-02-26 | MECH ENG [40 h]; MECH DES [40 h]; MECH TECH [120 h]; SCIENTIST [40 h] | 12,048.97 | 12,048.97 | 12104.8 | ELOUADRHIRI L | 1 | 1 |  | H | LATIFA E | 10-014 | 11-026 | 11 -035 | 0 |  |  |  |  |  |  |  |  |  |  |  |
| 142223010 |  | EC-P-#1 Prcrmnt Prep for Wave Shifting Fibers (FWD CAL) |  | 114d | 2009-09-07 A | 2010-02-26 A | 142223000M, 142223005 FS-20d | 100% | 2009-09-08 | 2010-02-26 |  |  |  | 0 | ELOUADRHIRI L | 1 | 1 |  | Z | LATIFA E | 10-014 | 11-026 | 11 -035 |  |  |  |  |  |  |  |  |  |  |  |  |
| 142223020 |  | EC-P-#1 Prcrmnt Prep for Light Guides & Accessr's (FWD CAL) |  | 20d | 2009-09-07 A | 2009-09-07 A | 142223000M | 100% | 2009-09-08 | 2009-10-05 |  |  |  | 0 | ELOUADRHIRI L | 1 | 1 |  | Z | LATIFA E | 10-014 | 11-026 | 11 -035 |  |  |  |  |  |  |  |  |  |  |  |  |
| 142223022 |  | EC-P-#1 Vend Fab of Light Guides & Accessr's (FWD CAL) |  | 160d | 2009-11-02 A | 2010-06-28 A | 9-100M FS+60d, 142223020 FS-500d | 100% |  |  | SCIENTIST [20 h]; PROCUREMENT<$50K 60; PROCUREMENT>$50K 69 | 64,835.99 | 1,326.2 | 64835.992074 | ELOUADRHIRI L | 1 | 1 |  | D | LATIFA E | 10-014 | 11-026 | 11 -035 | 0 | APP |  | 0 | 63509.792074 | 6350979.2074 | 100 |  |  |  |  |  |
| 142223012 |  | EC-P-#1 Vend Fab of Wave Shifting Fibers (FWD CAL) |  | 32d | 2009-11-23 A | 2010-01-18 A | 9-100M, 142223010 FS-200d | 100% | 2009-11-23 | 2010-01-15 | PROCUREMENT>$50K 69; SCIENTIST [20 h] | 2,192.59 | 1,326.2 | 2192.59 | ELOUADRHIRI L | 1 | 1 |  | D | LATIFA E | 10-014 | 11-026 | 11 -035 | 0 | APP | 10-011 | 0 | 866.39 | 86639 | 100 |  |  |  |  |  |
| 142223037 |  | EC-P-#2 Vend Fab of Wave Shifting Fibers (FWD CAL) |  | 43d | 2010-01-18 A | 2010-03-19 A | 142223012, 9-110M FS-250d | 100% | 2010-01-19 | 2010-03-19 | PROCUREMENT>$50K 69; SCIENTIST [20 h] | 126,048.23 | 1,326.2 | 126090.63 | ELOUADRHIRI L | 1 | 1 |  | D | LATIFA E | 10-014 | 11-026 | 11 -035 | 0 | APP |  | 0 | 124722.03 | 12472203 | 100 |  |  |  |  |  |
| 142223105 |  | Scintillator Procurement |  | 80d | 2010-04-01 A | 2010-07-23 A | 9-100M FS+120d, 142223100M | 100% |  |  | PROCUREMENT<$50K 60; PROCUREMENT>$50K 69 | 97,807.41 |  | 97807.41 | ELOUADRHIRI L | 1 | 1 |  | D | LATIFA E | 10-014 | 11-026 | 11 -035 | 0 |  |  | 0 | 97807.41 | 9780741 | 100 |  |  |  |  |  |
| 142223185 |  | Complete Manufacturing Drawings for Box Assy |  | 74d | 2010-04-01 A | 2010-07-15 A | 9-100M FS+130d | 100% |  |  | VISTNG USERS [200 h]; PD UNIV STAFF [102.8 h] | 9,054.76 | 9,054.76 | 9054.756 | ELOUADRHIRI L | 1 | 1 |  | H | LATIFA E | 10-014 | 11-026 | 11 -035 | 0 |  |  |  |  |  |  | 12-007 | 12-054F |  |  |  |
| 142223100M |  | PCAL Manufacturing Preparation - Milestone | milestone | 0d | 2010-05-03 A | 2010-05-03 A | 9-100M FS+120d | 100% | 2010-06-01 | 2010-06-01 |  |  |  | 0 | ELOUADRHIRI L | 1 | 1 |  | M | LATIFA E | 10-014 | 11-026 | 11 -035 |  |  |  |  |  |  |  |  |  |  |  |  |
| 142223195 |  | Prepare workspace |  | 40d | 2010-05-03 A | 2010-06-28 A | 9-100M FS+142d | 100% |  |  | PD UNIV STUDNT [40 h]; CONTRB UNIV LBR [400 h]; MECH TECH [160 h]; VISTNG USERS [160 h] | 9,983.2 | 9,983.2 | 9983.2 | ELOUADRHIRI L | 1 | 1 |  | H | LATIFA E | 10-014 | 11-026 | 11 -035 | 0 |  |  |  |  |  |  | 12-007 |  |  |  |  |
| 142223110 |  | W&M - Prepare workspace |  | 2d | 2010-05-17 A | 2010-05-18 A | 142223105 FS-41d | 100% |  |  |  |  |  | 0 | ELOUADRHIRI L | 1 | 1 |  | Z | LATIFA E | 10-014 | 11-026 | 11 -035 |  |  |  |  |  |  |  |  |  |  |  |  |
| 142223115 |  | Scintillator Processing |  | 150d | 2010-05-18 A | 2010-12-20 A | 142223110, 142223105 FS-65d | 100% |  |  | MECH TECH [120 h] | 5,067.32 | 5,067.32 | 5008.8 | ELOUADRHIRI L | 1 | 1 |  | H | LATIFA E | 10-014 | 11-026 | 11 -035 | 0 |  |  |  |  |  |  |  |  |  |  |  |
| 142223320 |  | Prepare workspace |  | 21d | 2010-05-28 A | 2010-06-28 A | 142223195 | 100% |  |  | VISTNG USERS [248 h]; PD UNIV STUDNT [120 h]; MECH TECH [124 h]; CONTRB UNIV LBR [360 h] | 10,879.36 | 10,879.36 | 10879.36 | ELOUADRHIRI L | 1 | 1 |  | H | LATIFA E | 10-014 | 11-026 | 11 -035 | 0 |  |  |  |  |  |  | 12-007 |  |  |  |  |
| 142223316 |  | JMU PMT and Divider assembly and test |  | 159d | 2010-06-01 A | 2011-01-24 A | 9-100M FS+164d | 100% |  |  |  |  |  | 0 | ELOUADRHIRI L | 1 | 1 |  | Z | LATIFA E | 10-014 | 11-026 | 11 -035 |  |  |  |  |  |  |  | 12-007 |  |  |  |  |
| 142223318 |  | Procurement- PMT Housing Components |  | 118d | 2010-06-01 A | 2010-11-15 A | 9-100M FS+142d | 100% |  |  | PROCUREMENT<$50K 60 NO ESCALATION FY11 | 40,000 |  | 40000 | ELOUADRHIRI L | 1 | 1 |  | D | LATIFA E | 10-014 | 11-026 | 11 -035 | 0 |  |  | 0 | 40000 | 4000000 | 100 | 12-007 |  |  |  |  |
| 142223120 |  | W&M NSF - Fiber procurement |  | 102d | 2010-06-23 A | 2010-11-15 A | 142223115, 9-100M FS+163d | 100% |  |  |  |  |  | 0 | ELOUADRHIRI L | 1 | 1 |  | Z | LATIFA E | 10-014 | 11-026 | 11 -035 |  |  |  |  |  |  |  |  |  |  |  |  |
| 142223193 |  | Procurement of lead sheets |  | 354d | 2010-07-01 A | 2011-12-01 A | 9-100M FS+151d | 100% |  |  | PROCUREMENT>$50K 69 NO ESCALATION FY11; PROCUREMENT<$50K 60 NO ESCALATION FY11 | 90,000 |  | 90000 | ELOUADRHIRI L | 1 | 1 |  | D | LATIFA E | 10-014 | 11-026 | 11 -035 | 0 |  |  | 0 | 90000 | 9000000 | 100 | 12-007 | 12-054F |  |  |  |
| 142223194 |  | FCAL Prepare EEL 125 Room & Floors |  | 2d | 2010-07-01 A | 2010-07-05 A | 9-100M FS+184d | 100% | 2010-07-01 | 2010-07-02 | MECH TECH [958.4 h] | 40,003.62 | 40,003.62 | 40003.616 | ELOUADRHIRI L | 1 | 1 |  | H | LATIFA E |  | 11-026 | 11 -035 | 0 |  |  |  |  |  |  | 12-007 | 12-054F | 10-060 |  |  |
| 142223186 |  | Issue PRs and Review Bids |  | 86d | 2010-07-16 A | 2010-11-15 A | 142223185 | 100% |  |  | VISTNG USERS [40 h]; MECH DES [40 h]; MECH ENG [40 h]; PD UNIV STAFF [40 h] | 7,366.72 | 7,366.72 | 7280.4 | ELOUADRHIRI L | 1 | 1 |  | H | LATIFA E | 10-014 | 11-026 | 11 -035 | 0 |  |  |  |  |  |  | 12-007 | 12-054F |  |  |  |
| 142223191 |  | Procurement of box sidewalls |  | 293d | 2010-09-20 A | 2011-11-21 A | 142223186 FS-30d | 100% |  |  | PROCUREMENT>$50K 69; PROCUREMENT<$50K 60 | 154,785 |  | 154785 | ELOUADRHIRI L | 1 | 1 |  | D | LATIFA E | 10-014 | 11-026 | 11 -035 | 0 |  |  | 0 | 154785 | 15478500 | 100 | 12-007 | 12-054F |  |  |  |
| 142223200 |  | Prepare Components Module 1 FY10 |  | 72d | 2010-10-04 A | 2011-01-24 A | 142223192 FS-170d, 142223190 FS-190d, 142223191 FS-170d, 142223194 FS-40d, 142223193 FS-385d | 100% |  |  | PD UNIV STUDNT [22.22 h]; VISTNG USERS [48.89 h]; MECH TECH [48.89 h]; SUPPLIES & MATERIALS; CONTRB UNIV LBR [222.22 h] | 6,028.93 | 3,251.15 | 5928.4465 | ELOUADRHIRI L | 1 | 1 |  | H | LATIFA E | 10-014 | 11-026 | 11 -035 | 0 |  |  |  |  |  |  | 12-007 | 12-054F |  | 11-001 |  |
| 142223200a |  | Prepare Components Module 1 FY11 |  | 72d | 2010-10-04 A | 2011-01-24 A | 142223200 FS-60d | 100% |  |  | VISTNG USERS [39.11 h]; MECH TECH [39.11 h]; SUPPLIES & MATERIALS; CONTRB UNIV LBR [177.78 h]; PD UNIV STUDNT [17.78 h] | 4,893.96 | 2,600.85 | 4893.9532 | ELOUADRHIRI L | 1 | 1 |  | H | LATIFA E | 10-014 | 11-026 | 11 -035 | 0 |  |  |  |  |  |  | 12-007 | 12-054F |  | 11-001 |  |
| 142223192 |  | Procurement of box windows |  | 258d | 2010-10-11 A | 2011-10-24 A | 142223186 FS-30d | 100% |  |  | PROCUREMENT<$50K 60; PROCUREMENT>$50K 69 | 92,871 |  | 92871 | ELOUADRHIRI L | 1 | 1 |  | D | LATIFA E | 10-014 | 11-026 | 11 -035 | 0 |  |  | 0 | 92871 | 9287100 | 100 | 12-007 | 12-054F |  |  |  |
| 142223190 |  | Procurement of retainers and PMT supports |  | 174d | 2010-12-01 A | 2011-08-15 A | 142223186 FS+32d, 142223185 FS-10d | 100% |  |  | PROCUREMENT<$50K 60; PROCUREMENT>$50K 69 | 123,828 |  | 123828 | ELOUADRHIRI L | 1 | 1 |  | D | LATIFA E | 10-014 | 11-026 | 11 -035 | 0 |  |  | 0 | 123828 | 12382800 | 100 | 12-007 | 12-054F |  |  |  |
| 142223565 |  | Procurement of PMT's and Dividers |  | 14d | 2011-01-03 A | 2011-01-24 A | 9-120M FS+141d | 100% | 2011-01-04 | 2011-01-24 | PROCUREMENT<$50K 60 NO ESCALATION FY13; PROCUREMENT>$50K 69 NO ESCALATION FY13 | 79,328.91 |  | 79328.91 | ELOUADRHIRI L | 1 | 1 |  | D | LATIFA E | 10-014 | 11-026 | 11 -035 | 0 |  |  | 0 | 79328.91 | 7932891 | 100 |  |  |  |  |  |
| 142223205 |  | Assembly of box 1 |  | 40d | 2011-03-01 A | 2011-04-25 A | 142223200, 142223200a | 100% |  |  | MECH TECH [80 h]; VISTNG USERS [80 h]; PD UNIV STUDNT [40 h]; CONTRB UNIV LBR [400 h] | 5,357.6 | 5,357.6 | 5357.6 | ELOUADRHIRI L | 1 | 1 |  | H | LATIFA E | 10-014 | 11-026 | 11 -035 | 0 |  |  |  |  |  |  | 12-007 | 12-054F |  |  |  |
| 142223280 |  | Prepare Components Module 5 |  | 380d | 2011-03-14 A | 2012-09-17 A | 142223275 FS-300d | 100% |  |  | CONTRB UNIV LBR [60 h]; VISTNG USERS [88 h]; MECH TECH [88 h]; PD UNIV STUDNT [40 h]; SUPPLIES & MATERIALS | 11,292.94 | 5,968.85 | 11362.65 | ELOUADRHIRI L | 1 | 1 |  | H | LATIFA E | 10-014 | 11-026 | 11 -035 | 0 |  |  |  |  |  |  | 12-007 | 12-054F |  |  | OPC A |
| 142223300 |  | Prepare Components Module 6 |  | 499d | 2011-03-14 A | 2013-02-11 A | 142223295 FS-300d | 100% | 2011-03-14 | 2013-03-15 | CONTRB UNIV LBR [60 h]; VISTNG USERS [88 h]; MECH TECH [88 h]; PD UNIV STUDNT [40 h]; SUPPLIES & MATERIALS | 11,352.13 | 6,018.2 | 11362.65 | ELOUADRHIRI L | 1 | 1 |  | H | LATIFA E | 10-014 | 11-026 | 11 -035 | 0 |  |  |  |  |  |  | 12-007 |  |  |  | OPC A |
| 142223220 |  | Prepare Components Module 2 |  | 84d | 2011-03-21 A | 2011-07-18 A | 142223215 FS-70d | 100% |  |  | PD UNIV STUDNT [40 h]; MECH TECH [80 h]; VISTNG USERS [80 h]; SUPPLIES & MATERIALS; CONTRB UNIV LBR [80 h] | 10,517.1 | 5,357.6 | 10517.1 | ELOUADRHIRI L | 1 | 1 |  | H | LATIFA E | 10-014 | 11-026 | 11 -035 | 0 |  |  |  |  |  |  | 12-007 | 12-054F |  |  |  |
| 142223240 |  | Prepare Components Module 3 |  | 224d | 2011-03-21 A | 2012-02-13 A | 142223235 FS-130d | 100% |  |  | VISTNG USERS [80 h]; MECH TECH [80 h]; SUPPLIES & MATERIALS; CONTRB UNIV LBR [60 h]; PD UNIV STUDNT [40 h] | 10,583.44 | 5,423.94 | 10517.1 | ELOUADRHIRI L | 1 | 1 |  | H | LATIFA E | 10-014 | 11-026 | 11 -035 | 0 |  |  |  |  |  |  | 12-007 | 12-054F |  |  |  |
| 142223260 |  | Prepare Components Module 4 |  | 288d | 2011-03-21 A | 2012-05-14 A | 142223255 FS-225d | 100% |  |  | CONTRB UNIV LBR [60 h]; PD UNIV STUDNT [40 h]; VISTNG USERS [88 h]; MECH TECH [88 h]; SUPPLIES & MATERIALS | 11,109.31 | 5,949.81 | 11011.5 | ELOUADRHIRI L | 1 | 1 |  | H | LATIFA E | 10-014 | 11-026 | 11 -035 | 0 |  |  |  |  |  |  |  | 12-054F |  |  |  |
| 142223210 |  | Stacking #1 |  | 73d | 2011-04-04 A | 2011-07-18 A | 142223205 | 100% | 2011-04-04 | 2011-07-15 | PD UNIV STUDNT [40 h]; VISTNG USERS [360 h]; MECH TECH [240 h]; PD UNIV STAFF [240 h]; CONTRB UNIV LBR [400 h] | 30,561.2 | 30,561.2 | 30561.2 | ELOUADRHIRI L | 1 | 1 |  | H | LATIFA E | 10-014 | 11-026 | 11 -035 | 0 |  |  |  |  |  |  | 12-007 | 12-054F |  |  |  |
| 142223215 |  | Close Module 1 |  | 18d | 2011-07-18 A | 2011-08-10 A | 142223210 | 100% |  |  | MECH TECH [40 h]; VISTNG USERS [40 h]; PD UNIV STUDNT [40 h]; CONTRB UNIV LBR [40 h] | 2,885.6 | 2,885.6 | 2885.6 | ELOUADRHIRI L | 1 | 1 |  | H | LATIFA E | 10-014 | 11-026 | 11 -035 | 0 |  |  |  |  |  |  | 12-007 | 12-054F |  |  |  |
| 142223317 |  | Fiber Polisher FY10 |  | 26d | 2011-07-18 A | 2011-08-22 A | 9-100M FS+229d, 9-110M FS+205d | 100% |  |  | MSHOP | 9,500 |  | 9500 | ELOUADRHIRI L | 1 | 1 |  | H | LATIFA E | 10-014 | 11-026 | 11 -035 | 0 |  |  |  |  |  |  | 12-007 |  |  | 11-001 |  |
| 142223317a |  | Fiber Polisher FY11 |  | 26d | 2011-07-18 A | 2011-08-22 A | 142223317 FS-20d, 9-100M FS+229d | 100% |  |  | MSHOP | 515.95 |  | 515.95 | ELOUADRHIRI L | 1 | 1 |  | H | LATIFA E | 10-014 | 11-026 | 11 -035 | 0 |  |  |  |  |  |  | 12-007 |  |  | 11-001 |  |
| 142223225 |  | Assembly of box 2 |  | 39d | 2011-08-01 A | 2011-09-26 A | 142223220 | 100% | 2011-08-01 | 2011-09-23 | PD UNIV STUDNT [80 h]; VISTNG USERS [80 h]; MECH TECH [80 h]; CONTRB UNIV LBR [40 h] | 5,771.2 | 5,771.2 | 5771.2 | ELOUADRHIRI L | 1 | 1 |  | H | LATIFA E | 10-014 | 11-026 | 11 -035 | 0 |  |  |  |  |  |  | 12-007 | 12-054F |  |  |  |
| 142223325 |  | Setup module1 |  | 46d | 2011-09-19 A | 2011-11-21 A | 142223215, 142223320 | 100% |  |  | CONTRB UNIV LBR [40 h]; MECH TECH [24 h]; VISTNG USERS [48 h]; PD UNIV STUDNT [40 h] | 2,404.92 | 2,404.92 | 2346.32 | ELOUADRHIRI L | 1 | 1 |  | H | LATIFA E | 10-014 | 11-026 | 11 -035 | 0 |  |  |  |  |  |  | 12-007 |  |  |  |  |
| 142223330 |  | Prepare components |  | 73d | 2011-09-19 A | 2012-01-09 A | 142223317, 142223317a, 142223325 FS-20d | 100% |  |  | PD UNIV STUDNT [40 h]; MECH TECH [44 h]; VISTNG USERS [88 h]; CONTRB UNIV LBR [40 h] | 4,065.9 | 4,065.9 | 3956.92 | ELOUADRHIRI L | 1 | 1 |  | H | LATIFA E | 10-014 | 11-026 | 11 -035 | 0 |  |  |  |  |  |  | 12-007 |  |  |  |  |
| 142223230 |  | Stacking #2 |  | 67d | 2011-10-03 A | 2012-01-16 A | 142223225 | 100% | 2011-10-03 | 2012-01-13 | CONTRB UNIV LBR [80 h]; PD UNIV STUDNT [200 h]; VISTNG USERS [360 h]; MECH TECH [240 h]; PD UNIV STAFF [240 h] | 33,244 | 33,244 | 32215.6 | ELOUADRHIRI L | 1 | 1 |  | H | LATIFA E | 10-014 | 11-026 | 11 -035 | 0 |  |  |  |  |  |  | 12-007 | 12-054F |  |  |  |
| 142223232 |  | ETC Revision of Stacking #2 |  | 46d | 2011-11-01 A | 2012-01-16 A | 9-120M FS+21d | 100% | 2011-11-01 | 2012-01-13 | VISTNG USERS [452 h]; PD UNIV STAFF [148 h] | 17,053.28 | 17,053.28 | 17053.28 | ELOUADRHIRI L | 1 | 1 |  | H | LATIFA E | 10-014 | 11-026 | 11 -035 | 0 |  |  |  |  |  |  | 12-007 | 12-054F |  |  |  |
| 142223319 |  | WLS Fibers final set procurement |  | 73d | 2012-01-03 A | 2012-04-16 A | 9-120M FS+60d | 100% |  |  | PROCUREMENT>$50K 69; PROCUREMENT<$50K 60 | 58,000 |  | 58000 | ELOUADRHIRI L | 1 | 1 |  | D | LATIFA E |  |  |  | 0 |  |  | 0 | 58000 | 5800000 | 100 | 12-007 |  |  |  |  |
| 142223335 |  | Fiber/PMT assembly Module #1 |  | 5d | 2012-01-09 A | 2012-01-16 A | 142223330 FS-20d, 11022321000, 11022322000, 142223316 FS-285d, 142223318 FS-40d | 100% | 2012-01-09 | 2012-01-13 | PD UNIV STUDNT [120 h]; PD UNIV STAFF [248 h]; CONTRB UNIV LBR [120 h]; VISTNG USERS [248 h] | 20,009.36 | 20,009.36 | 19389.44 | ELOUADRHIRI L | 1 | 1 |  | H | LATIFA E | 10-014 | 11-026 | 11 -035 | 0 |  |  |  |  |  |  | 12-007 |  |  |  |  |
| 142223337 |  | ETC Revision of Fiber/PMT assembly Module #1 |  | 20d | 2012-01-16 A | 2012-02-13 A | 9-120M FS+42d | 100% | 2012-01-17 | 2012-02-13 | VISTNG USERS [372 h]; PD UNIV STAFF [124 h] | 14,158.32 | 14,158.32 | 14158.32 | ELOUADRHIRI L | 1 | 1 |  | H | LATIFA E | 10-014 | 11-026 | 11 -035 | 0 |  |  |  |  |  |  | 12-007 |  |  |  |  |
| 142223235 |  | Close Module 2 |  | 16d | 2012-01-23 A | 2012-02-13 A | 142223230, 142223232 FS-163d | 100% |  |  | CONTRB UNIV LBR [40 h]; PD UNIV STUDNT [40 h]; VISTNG USERS [48 h]; MECH TECH [48 h] | 3,487.76 | 3,487.76 | 3380 | ELOUADRHIRI L | 1 | 1 |  | H | LATIFA E | 10-014 | 11-026 | 11 -035 | 0 |  |  |  |  |  |  | 12-007 | 12-054F |  |  |  |
| 142223245 |  | Assembly of box 3 |  | 31d | 2012-02-01 A | 2012-03-16 A | 142223240 | 100% | 2012-02-01 | 2012-03-15 | VISTNG USERS [80 h]; MECH TECH [80 h]; CONTRB UNIV LBR [40 h]; PD UNIV STUDNT [40 h] | 5,528.4 | 5,528.4 | 5357.6 | ELOUADRHIRI L | 1 | 1 |  | H | LATIFA E | 10-014 | 11-026 | 11 -035 | 0 |  |  |  |  |  |  | 12-007 | 12-054F |  |  |  |
| 142223340 |  | Prepare #1 for test |  | 11d | 2012-02-01 A | 2012-02-15 A | 142223335, 142223337 FS-196d | 100% |  |  | CONTRB UNIV LBR [40 h]; PD UNIV STUDNT [40 h]; VISTNG USERS [88 h] | 2,127.84 | 2,127.84 | 2061.84 | ELOUADRHIRI L | 1 | 1 |  | H | LATIFA E | 10-014 | 11-026 | 11 -035 | 0 |  |  |  |  |  |  | 12-007 |  |  |  |  |
| 142223535 |  | Prepare the storage area |  | 32d | 2012-02-01 A | 2012-03-17 A | 142223350 FS-10d | 100% | 2012-02-01 | 2012-03-16 |  |  |  | 0 | ELOUADRHIRI L | 1 | 1 |  | Z | LATIFA E | 10-014 | 11-026 | 11 -035 |  |  |  |  |  |  |  |  |  |  |  |  |
| 142223345 |  | Testing #1 |  | 3d | 2012-02-16 A | 2012-02-21 A | 11022323000, 11022325000, 11022324000, 142223340 | 100% |  |  | PD UNIV STAFF [88 h]; VISTNG USERS [88 h]; CONTRB UNIV LBR [88 h] | 6,645.76 | 6,645.76 | 6439.84 | ELOUADRHIRI L | 1 | 1 |  | H | LATIFA E | 10-014 | 11-026 | 11 -035 | 0 |  |  |  |  |  |  | 12-007 |  |  |  |  |
| 142223360 |  | Setup module2 |  | 19d | 2012-02-19 A | 2012-03-17 A | 142223355 FS-15d, 142223235 | 100% | 2012-02-21 | 2012-03-16 | PD UNIV STUDNT [40 h]; VISTNG USERS [48 h]; CONTRB UNIV LBR [40 h]; MECH TECH [24 h] | 2,421.2 | 2,421.2 | 2346.32 | ELOUADRHIRI L | 1 | 1 |  | H | LATIFA E | 10-014 | 11-026 | 11 -035 | 0 |  |  |  |  |  |  | 12-007 |  |  |  |  |
| 142223350 |  | Disassemble #1 |  | 2d | 2012-03-01 A | 2012-03-05 A | 142223345 | 100% | 2012-03-01 | 2012-03-02 | VISTNG USERS [48 h]; CONTRB UNIV LBR [40 h]; PD UNIV STUDNT [40 h] | 1,354.64 | 1,354.64 | 1312.64 | ELOUADRHIRI L | 1 | 1 |  | H | LATIFA E | 10-014 | 11-026 | 11 -035 | 0 |  |  |  |  |  |  | 12-007 |  |  |  |  |
| 142223355 |  | Move #1 to storage |  | 3d | 2012-03-05 A | 2012-03-08 A | 142223350 | 100% | 2012-03-05 | 2012-03-07 | MECH TECH [16 h] | 711.04 | 711.04 | 689.12 | ELOUADRHIRI L | 1 | 1 |  | H | LATIFA E | 10-014 | 11-026 | 11 -035 | 0 |  |  |  |  |  |  | 12-007 |  |  |  |  |
| 142223365 |  | Prepare components |  | 5d | 2012-03-12 A | 2012-03-19 A | 142223360 | 100% | 2012-03-12 | 2012-03-16 | VISTNG USERS [88 h]; CONTRB UNIV LBR [40 h]; MECH TECH [44 h]; PD UNIV STUDNT [40 h] | 4,083.2 | 4,083.2 | 3956.92 | ELOUADRHIRI L | 1 | 1 |  | H | LATIFA E | 10-014 | 11-026 | 11 -035 | 0 |  |  |  |  |  |  | 12-007 |  |  |  |  |
| 142223370 |  | Fiber/PMT assembly Module #2 |  | 5d | 2012-03-12 A | 2012-03-19 A | 142223365 | 100% | 2012-03-12 | 2012-03-16 | PD UNIV STUDNT [120 h]; PD UNIV STAFF [248 h]; CONTRB UNIV LBR [120 h]; VISTNG USERS [248 h] | 20,009.36 | 20,009.36 | 19389.44 | ELOUADRHIRI L | 1 | 1 |  | H | LATIFA E | 10-014 | 11-026 | 11 -035 | 0 |  |  |  |  |  |  | 12-007 |  |  |  |  |
| 142223540 |  | Store module #1 |  | 5d | 2012-03-12 A | 2012-03-19 A | 142223535, 142223355 | 100% | 2012-03-12 | 2012-03-16 |  |  |  | 0 | ELOUADRHIRI L | 1 | 1 |  | Z | LATIFA E | 10-014 | 11-026 | 11 -035 |  |  |  |  |  |  |  |  |  |  |  |  |
| 142223250 |  | Stacking #3 |  | 41d | 2012-03-17 A | 2012-05-14 A | 142223245 | 100% | 2012-03-19 | 2012-05-14 | CONTRB UNIV LBR [80 h]; PD UNIV STUDNT [160 h]; VISTNG USERS [360 h]; MECH TECH [240 h]; PD UNIV STAFF [240 h] | 32,817.2 | 32,817.2 | 31802 | ELOUADRHIRI L | 1 | 1 |  | H | LATIFA E | 10-014 | 11-026 | 11 -035 | 0 |  |  |  |  |  |  | 12-007 | 12-054F |  |  |  |
| 142223252 |  | ETC Revision of Stacking #3 |  | 41d | 2012-03-17 A | 2012-05-14 A | 9-120M FS+62d, 142223245 | 100% | 2012-03-19 | 2012-05-14 | PD UNIV STAFF [148 h]; VISTNG USERS [452 h] | 17,053.28 | 17,053.28 | 17053.28 | ELOUADRHIRI L | 1 | 1 |  | H | LATIFA E | 10-014 | 11-026 | 11 -035 | 0 |  |  |  |  |  |  | 12-007 | 12-054F |  |  |  |
| 142223372 |  | ETC Revision of Fiber/PMT assembly Module #2 |  | 5d | 2012-03-19 A | 2012-03-26 A | 9-120M FS+120d | 100% | 2012-03-19 | 2012-03-23 | VISTNG USERS [372 h]; PD UNIV STAFF [44 h] | 9,663.12 | 9,663.12 | 9663.12 | ELOUADRHIRI L | 1 | 1 |  | H | LATIFA E | 10-014 | 11-026 | 11 -035 | 0 |  |  |  |  |  |  | 12-007 |  |  |  |  |
| 142223375 |  | Prepare #2 for test |  | 5d | 2012-03-19 A | 2012-03-26 A | 142223370 FS-25d, 142223372 FS-196d | 100% | 2012-03-19 | 2012-03-23 | CONTRB UNIV LBR [80 h]; PD UNIV STUDNT [40 h]; VISTNG USERS [88 h] | 2,127.84 | 2,127.84 | 2061.84 | ELOUADRHIRI L | 1 | 1 |  | H | LATIFA E | 10-014 | 11-026 | 11 -035 | 0 |  |  |  |  |  |  | 12-007 |  |  |  |  |
| 142223380 |  | Testing #2 |  | 16d | 2012-03-26 A | 2012-04-16 A | 142223375 | 100% |  |  | VISTNG USERS [88 h]; PD UNIV STAFF [88 h]; CONTRB UNIV LBR [88 h] | 6,645.76 | 6,645.76 | 6439.84 | ELOUADRHIRI L | 1 | 1 |  | H | LATIFA E | 10-014 | 11-026 | 11 -035 | 0 |  |  |  |  |  |  | 12-007 |  |  |  |  |
| 142223385 |  | Disassemble #2 |  | 26d | 2012-04-09 A | 2012-05-14 A | 142223380 | 100% |  |  | PD UNIV STUDNT [40 h]; CONTRB UNIV LBR [40 h]; VISTNG USERS [48 h] | 1,354.64 | 1,354.64 | 1312.64 | ELOUADRHIRI L | 1 | 1 |  | H | LATIFA E | 10-014 | 11-026 | 11 -035 | 0 |  |  |  |  |  |  | 12-007 |  |  |  |  |
| 142223255 |  | Close Module 3 |  | 10d | 2012-05-01 A | 2012-05-14 A | 142223250, 142223252 FS-163d | 100% |  |  | CONTRB UNIV LBR [40 h]; PD UNIV STUDNT [40 h]; VISTNG USERS [48 h]; MECH TECH [48 h] | 3,487.76 | 3,487.76 | 3380 | ELOUADRHIRI L | 1 | 1 |  | H | LATIFA E | 10-014 | 11-026 | 11 -035 | 0 |  |  |  |  |  |  | 12-007 | 12-054F |  |  |  |
| 142223545 |  | Store module #2 |  | 10d | 2012-05-01 A | 2012-05-14 A | 142223540, 142223390 | 100% |  |  |  |  |  | 0 | ELOUADRHIRI L | 1 | 1 |  | Z | LATIFA E | 10-014 | 11-026 | 11 -035 |  |  |  |  |  |  |  |  |  |  |  |  |
| 142223390 |  | Move #2 to storage |  | 2d | 2012-05-14 A | 2012-05-15 A | 142223385 | 100% |  |  | MECH TECH [16 h] | 711.04 | 711.04 | 689.12 | ELOUADRHIRI L | 1 | 1 |  | H | LATIFA E | 10-014 | 11-026 | 11 -035 | 0 |  |  |  |  |  |  | 12-007 |  |  |  |  |

Notes:
- 142223535: Explanation: space required from the lab.

| ID | Activity | Type | Duration | Start | Finish | Predecessors | Complete | Remaining | Planned start | Planned finish | Total float | Free float | Calendar | Resources | Cost | Actual cost | Calculated Remaining Total Cost | MONTHLY EV COST | RESP - Responsibility | STRT%COMP for CM EVM | FNSH%COMP for CM EVM | EVMS Reporting Codes | CAM RESPONSIBLE | CR 10-014 | CR 11-026 | CR 11-035 | CR 12-001 | CR 12-054 | CR 12-007 | OPC Allison | CR 12-053 | MARCH!!! | CR 11-038 | Remaining Material Cost Based on % Compl | Claimed Material Cost Based on % Complet | Initial Claimed Material Calc | Claimed Material Divider | ReBaseline Actuals Adjustment | Original Activity ID Rebaseline | PRIOR MONTH EV COST | CR 13-002 | CR 13-010 | BOE Procurement | BOE Labor | CR 13-015 | Post Rebaseline | Obligated Prior to Rebaseline | CR 14-001 |
| --- | --- | --- | --- | --- | --- | --- | --- | --- | --- | --- | --- | --- | --- | --- | --- | --- | --- | --- | --- | --- | --- | --- | --- | --- | --- | --- | --- | --- | --- | --- | --- | --- | --- | --- | --- | --- | --- | --- | --- | --- | --- | --- | --- | --- | --- | --- | --- | --- |
| 142223265 | Assembly of box 4 FY11 |  | 18d | 2012-05-15 A | 2012-06-11 A | 142223255, 142223260 | 100% |  |  |  |  |  |  | CONTRB UNIV LBR [21.82 h]; VISTNG USERS [48 h]; PD UNIV STUDNT [21.82 h]; MECH TECH [48 h] | 3,293.78 | 3,293.78 | 0 | 3192.0188 | ELOUADRHIRI L | 1 | 1 | H | LATIFA E | 10-014 | 11-026 | 11 -035 | 12-001 | 12-054F |  |  |  |  |  |  |  |  |  |  |  |  |  |  |  |  |  |  |  |  |
| 142223265a | Assembly of box 4 FY12 |  | 18d | 2012-05-15 A | 2012-06-11 A | 142223265 FS-15d | 100% |  |  |  |  |  |  | PD UNIV STUDNT [18.18 h]; MECH TECH [40 h]; CONTRB UNIV LBR [18.18 h]; VISTNG USERS [40 h] | 2,744.78 | 2,744.78 | 0 | 2744.7806 | ELOUADRHIRI L | 1 | 1 | H | LATIFA E | 10-014 | 11-026 | 11 -035 | 12-001 | 12-054F |  |  |  |  |  |  |  |  |  |  |  |  |  |  |  |  |  |  |  |  |
| 142223395 | Setup module3 |  | 11d | 2012-05-18 A | 2012-06-05 A | 142223390, 142223255 | 100% |  |  |  |  |  |  | CONTRB UNIV LBR [40 h]; VISTNG USERS [48 h]; PD UNIV STUDNT [40 h]; MECH TECH [24 h] | 2,421.2 | 2,421.2 | 0 | 2346.32 | ELOUADRHIRI L | 1 | 1 | H | LATIFA E | 10-014 | 11-026 | 11 -035 |  |  | 12-007 |  |  |  |  |  |  |  |  |  |  |  |  |  |  |  |  |  |  |  |
| 142223400 | Prepare components FY11 |  | 5d | 2012-06-02 A | 2012-06-11 A | 142223395 FS-10d | 100% |  | 2012-06-05 | 2012-06-11 |  |  |  | CONTRB UNIV LBR [32.73 h]; VISTNG USERS [72 h]; MECH TECH [36 h]; PD UNIV STUDNT [32.73 h] | 3,340.83 | 3,340.83 | 0 | 3237.5082 | ELOUADRHIRI L | 1 | 1 | H | LATIFA E | 10-014 | 11-026 | 11 -035 | 12-001 |  | 12-007 |  |  |  |  |  |  |  |  |  |  |  |  |  |  |  |  |  |  |  |
| 142223400a | Prepare components FY12 |  | 6d | 2012-06-09 A | 2012-06-18 A | 142223400 | 100% |  | 2012-06-11 | 2012-06-18 |  |  |  | CONTRB UNIV LBR [7.27 h]; VISTNG USERS [16 h]; MECH TECH [8 h]; PD UNIV STUDNT [7.27 h] | 742.37 | 742.37 | 0 | 742.3709 | ELOUADRHIRI L | 1 | 1 | H | LATIFA E | 10-014 | 11-026 | 11 -035 | 12-001 |  | 12-007 |  |  |  |  |  |  |  |  |  |  |  |  |  |  |  |  |  |  |  |
| 142223270 | Stacking #4 |  | 49d | 2012-06-11 A | 2012-08-16 A | 142223265a | 100% |  |  |  |  |  |  | PD UNIV STAFF [83.48 h]; CONTRB UNIV LBR [27.83 h]; VISTNG USERS [125.22 h]; PD UNIV STUDNT [41.74 h]; MECH TECH [83.48 h] | 11,266.46 | 11,266.46 | 0 | 11266.564599 | ELOUADRHIRI L | 1 | 1 | H | LATIFA E | 10-014 | 11-026 | 11 -035 |  | 12-054F | 12-007 | OPC A |  |  |  |  |  |  |  |  |  |  |  |  |  |  |  |  |  |  |
| 142223272 | Stacking #4 Revised |  | 49d | 2012-06-11 A | 2012-08-16 A | 142223270 FS-60d, 9-120M | 100% |  |  |  |  |  |  | PD UNIV STAFF [304.4 h]; CONTRB UNIV LBR [52.17 h]; VISTNG USERS [686.8 h]; PD UNIV STUDNT [78.26 h]; MECH TECH [156.52 h] | 38,170.86 | 38,170.86 | 0 | 38170.863 | ELOUADRHIRI L | 1 | 1 | H | LATIFA E | 10-014 | 11-026 | 11 -035 |  | 12-054F | 12-007 | OPC A |  |  |  |  |  |  |  |  |  |  |  |  |  |  |  |  |  |  |
| 142223405 | Fiber/PMT assembly Module #3 |  | 10d | 2012-06-11 A | 2012-06-22 A | 142223400a | 100% |  |  |  |  |  |  | PD UNIV STUDNT [73.55 h]; CONTRB UNIV LBR [73.55 h]; VISTNG USERS [152 h]; PD UNIV STAFF [152 h] | 12,263.82 | 12,263.82 | 0 | 12263.888993 | ELOUADRHIRI L | 1 | 1 | H | LATIFA E | 10-014 | 11-026 | 11 -035 |  |  | 12-007 |  |  |  |  |  |  |  |  |  |  |  |  |  |  |  |  |  |  |  |
| 142223410 | Prepare #3 for test |  | 6d | 2012-06-18 A | 2012-06-25 A | 142223407, 142223405 | 100% |  |  |  |  |  |  | CONTRB UNIV LBR [40 h]; VISTNG USERS [88 h]; PD UNIV STUDNT [40 h] | 2,127.84 | 2,127.84 | 0 | 2127.84 | ELOUADRHIRI L | 1 | 1 | H | LATIFA E | 10-014 | 11-026 | 11 -035 |  |  | 12-007 |  |  |  |  |  |  |  |  |  |  |  |  |  |  |  |  |  |  |  |
| 142223415 | Testing #3 FY12 |  | 20d | 2012-06-18 A | 2012-07-15 A | 142223410 FS-10d | 100% |  | 2012-06-18 | 2012-07-13 |  |  |  | VISTNG USERS [56 h]; CONTRB UNIV LBR [56 h]; PD UNIV STAFF [56 h] | 4,229.12 | 4,229.12 | 0 | 4229.12 | ELOUADRHIRI L | 1 | 1 | H | LATIFA E | 10-014 | 11-026 | 11 -035 |  |  | 12-007 |  | 12-053 |  |  |  |  |  |  |  |  |  |  |  |  |  |  |  |  |  |
| 142223415a | Testing #3 FY13 |  | 20d | 2012-06-18 A | 2012-07-15 A | 142223415 | 100% |  | 2012-06-18 | 2012-07-13 |  |  |  | VISTNG USERS [32 h]; CONTRB UNIV LBR [32 h]; PD UNIV STAFF [32 h] | 2,416.64 | 2,416.64 | 0 | 2493.76 | ELOUADRHIRI L | 1 | 1 | H | LATIFA E | 10-014 | 11-026 | 11 -035 |  |  | 12-007 |  | 12-053 |  |  |  |  |  |  |  |  |  |  |  |  |  |  |  |  |  |
| 142223407 | Fiber/PMT assembly Revised Module #3 |  | 4d | 2012-06-19 A | 2012-06-22 A | 9-120M FS+198d, 142223405 FS-15d | 100% |  |  |  |  |  |  | CONTRB UNIV LBR [46.45 h]; PD UNIV STUDNT [46.45 h]; VISTNG USERS [468 h]; PD UNIV STAFF [140 h] | 17,408.66 | 17,408.66 | 0 | 17408.6615 | ELOUADRHIRI L | 1 | 1 | H | LATIFA E | 10-014 | 11-026 | 11 -035 |  |  | 12-007 |  |  |  |  |  |  |  |  |  |  |  |  |  |  |  |  |  |  |  |
| 142223420 | Disassemble #3 |  | 22d | 2012-07-16 A | 2012-08-14 A | 142223415a | 100% |  |  |  |  |  |  | CONTRB UNIV LBR [40 h]; PD UNIV STUDNT [40 h]; VISTNG USERS [48 h] | 1,354.64 | 1,354.64 | 0 | 1398 | ELOUADRHIRI L | 1 | 1 | H | LATIFA E | 10-014 | 11-026 | 11 -035 |  |  | 12-007 |  |  |  |  |  |  |  |  |  |  |  |  |  |  |  |  |  |  |  |
| 142223425 | Move #3 to storage |  | 8d | 2012-08-17 A | 2012-08-28 A | 142223420 | 100% |  |  |  |  |  |  | MECH TECH [16 h] | 711.04 | 711.04 | 0 | 733.76 | ELOUADRHIRI L | 1 | 1 | H | LATIFA E | 10-014 | 11-026 | 11 -035 |  |  | 12-007 | OPC A |  |  |  |  |  |  |  |  |  |  |  |  |  |  |  |  |  |  |
| 142223550 | Store module #3 |  | 6d | 2012-08-20 A | 2012-08-27 A | 142223545, 142223425 | 100% |  |  |  |  |  |  |  |  |  |  | 0 | ELOUADRHIRI L | 1 | 1 | Z | LATIFA E | 10-014 | 11-026 | 11 -035 |  |  | 12-007 | OPC A |  |  |  |  |  |  |  |  |  |  |  |  |  |  |  |  |  |  |
| 142223275 | Close Module 4 |  | 10d | 2012-09-03 A | 2012-09-17 A | 142223272, 142223270 | 100% |  | 2012-09-04 | 2012-09-17 |  |  |  | CONTRB UNIV LBR [40 h]; VISTNG USERS [48 h]; MECH TECH [48 h]; PD UNIV STUDNT [40 h] | 3,487.76 | 3,487.76 | 0 | 3487.76 | ELOUADRHIRI L | 1 | 1 | H | LATIFA E | 10-014 | 11-026 | 11 -035 |  | 12-054F | 12-007 | OPC A |  |  |  |  |  |  |  |  |  |  |  |  |  |  |  |  |  |  |
| 142223430 | Setup module 4 |  | 5d | 2012-09-03 A | 2012-09-10 A | 142223425, 142223275 FS-5d | 100% |  | 2012-09-04 | 2012-09-10 |  |  |  | MECH TECH [24 h]; PD UNIV STUDNT [40 h]; VISTNG USERS [48 h]; CONTRB UNIV LBR [40 h] | 2,421.2 | 2,421.2 | 0 | 2498.64 | ELOUADRHIRI L | 1 | 1 | H | LATIFA E | 10-014 | 11-026 | 11 -035 |  |  | 12-007 | OPC A |  |  |  |  |  |  |  |  |  |  |  |  |  |  |  |  |  |  |
| 142223435 | Prepare components |  | 6d | 2012-09-10 A | 2012-09-17 A | 142223430 FS-5d | 100% |  |  |  |  |  |  | CONTRB UNIV LBR [40 h]; PD UNIV STUDNT [40 h]; VISTNG USERS [88 h]; MECH TECH [44 h] | 4,083.2 | 4,083.2 | 0 | 4213.84 | ELOUADRHIRI L | 1 | 1 | H | LATIFA E | 10-014 | 11-026 | 11 -035 |  |  | 12-007 | OPC A |  |  |  |  |  |  |  |  |  |  |  |  |  |  |  |  |  |  |
| 142223285 | Assembly of box 5 FY12 |  | 20d | 2012-09-17 A | 2012-10-12 A | 142223280 FS-10d | 100% |  |  |  |  |  |  | CONTRB UNIV LBR [14.55 h]; VISTNG USERS [32 h]; MECH TECH [32 h]; PD UNIV STUDNT [14.55 h] | 2,231 | 2,231 | 0 | 2195.8885 | ELOUADRHIRI L | 1 | 1 | H | LATIFA E | 10-014 | 11-026 | 11 -035 |  | 12-054F | 12-007 | OPC A | 12-053 |  |  |  |  |  |  |  |  |  |  |  |  |  |  |  |  |  |
| 142223285a | Assembly of box 5 FY13 |  | 20d | 2012-09-17 A | 2012-10-12 A | 142223285 FS-20d | 100% |  |  |  |  |  |  | CONTRB UNIV LBR [25.45 h]; VISTNG USERS [56 h]; MECH TECH [56 h]; PD UNIV STUDNT [25.45 h] | 3,904.12 | 3,904.12 | 0 | 3965.5645 | ELOUADRHIRI L | 1 | 1 | H | LATIFA E | 10-014 | 11-026 | 11 -035 |  | 12-054F | 12-007 |  | 12-053 |  |  |  |  |  |  |  |  |  |  |  |  |  |  |  |  |  |
| 142223440 | Fiber/PMT assembly Module #4 |  | 20d | 2012-09-17 A | 2012-10-12 A | 142223435 | 100% |  |  |  |  |  |  | CONTRB UNIV LBR [120 h]; VISTNG USERS [620 h]; PD UNIV STUDNT [120 h]; PD UNIV STAFF [292 h] | 30,146.42 | 30,146.42 | 0 | 30620.36 | ELOUADRHIRI L | 1 | 1 | U | LATIFA E | 10-014 | 11-026 | 11 -035 |  |  | 12-007 | OPC A |  |  |  |  |  |  |  |  |  |  |  |  |  |  |  |  |  |  |
| 142223445 | Prepare #4 for test |  | 11d | 2012-10-13 A | 2012-10-29 A | 142223440 | 100% |  | 2012-10-15 | 2012-10-29 |  |  |  | CONTRB UNIV LBR [40 h]; PD UNIV STUDNT [40 h]; VISTNG USERS [88 h] | 2,196 | 2,196 | 0 | 2196 | ELOUADRHIRI L | 1 | 1 | H | LATIFA E | 10-014 | 11-026 | 11 -035 |  |  | 12-007 | OPC A |  |  |  |  |  |  |  |  |  |  |  |  |  |  |  |  |  |  |
| 142223290 | Stacking #5 |  | 83d | 2012-10-15 A | 2013-01-31 A | 142223285a FS+12d | 100% |  | 2012-10-15 | 2013-02-20 |  |  |  | PD UNIV STUDNT [120 h]; PD UNIV STAFF [388 h]; CONTRB UNIV LBR [80 h]; VISTNG USERS [812 h]; MECH TECH [240 h] | 51,023.24 | 51,023.24 | 0 | 51023.24 | ELOUADRHIRI L | 1 | 1 | U | LATIFA E | 10-014 | 11-026 | 11 -035 |  | 12-054 | 12-007 | OPC A |  | XX |  |  |  |  |  |  |  |  |  |  |  |  |  |  |  |  |
| 142223450 | Testing #4 |  | 54d | 2012-10-22 A | 2013-01-21 A | 142223445 | 100% |  | 2012-10-22 | 2013-01-15 |  |  |  | PD UNIV STAFF [88 h]; VISTNG USERS [88 h]; CONTRB UNIV LBR [88 h] | 6,857.84 | 6,857.84 | 0 | 6857.84 | ELOUADRHIRI L | 1 | 1 | H | LATIFA E | 10-014 | 11-026 | 11 -035 |  |  | 12-007 | OPC A |  | XX |  |  |  |  |  |  |  |  |  |  |  |  |  |  |  |  |
| 142223455 | Disassemble #4 |  | 7d | 2013-01-14 A | 2013-01-24 A | 142223450 | 100% |  | 2013-02-01 | 2013-02-11 |  |  |  | CONTRB UNIV LBR [40 h]; VISTNG USERS [48 h]; PD UNIV STUDNT [40 h] | 1,398 | 1,398 | 0 | 1398 | ELOUADRHIRI L | 1 | 1 | H | LATIFA E | 10-014 | 11-026 | 11 -035 |  |  | 12-007 | OPC A |  | XX |  |  |  |  |  |  |  |  |  |  |  |  |  |  |  |  |
| 142223570 | Repair Calorimeter PMT's |  | 35d | 2013-01-14 A | 2013-05-13 A | 142223565, 9-130M FS+24d | 100% |  | 2013-01-14 | 2013-03-05 |  |  |  | VISTNG USERS [160 h]; MECH TECH [480 h]; PD UNIV STAFF [120 h] | 32,162.4 | 32,162.4 | 0 | 32162.4 | ELOUADRHIRI L | 1 | 1 | U | LATIFA E | 10-014 | 11-026 | 11 -035 |  |  | 12-007 |  |  | XX | 11-038 |  |  |  |  |  |  |  |  |  |  |  |  |  |  |  |
| 142223295 | Close Module 5 |  | 6d | 2013-01-16 A | 2013-01-21 A | 142223290 | 100% |  | 2013-03-22 | 2013-03-29 |  |  |  | MECH TECH [48 h]; PD UNIV STUDNT [40 h]; CONTRB UNIV LBR [40 h]; VISTNG USERS [48 h] | 3,599.28 | 3,599.28 | 0 | 3599.28 | ELOUADRHIRI L | 1 | 1 | H | LATIFA E | 10-014 | 11-026 | 11 -035 |  | 12-054 | 12-007 | OPC A |  | XX |  |  |  |  |  |  |  |  |  |  |  |  |  |  |  |  |
| 142223460 | Move #4 to storage |  | 2d | 2013-02-01 A | 2013-02-04 A | 142223455 | 100% |  | 2013-03-01 | 2013-03-04 |  |  |  | MECH TECH [16 h] | 733.76 | 733.76 | 0 | 733.76 | ELOUADRHIRI L | 1 | 1 | H | LATIFA E | 10-014 | 11-026 | 11 -035 |  |  | 12-007 | OPC A |  | XX |  |  |  |  |  |  |  |  |  |  |  |  |  |  |  |  |
| 142223555 | Store module #4 |  | 1d | 2013-02-01 A | 2013-02-01 A | 142223550, 142223460 | 100% |  | 2013-03-01 | 2013-03-01 |  |  |  |  |  |  |  | 0 | ELOUADRHIRI L | 1 | 1 | Z | LATIFA E | 10-014 | 11-026 | 11 -035 |  |  | 12-007 | OPC A |  | XX |  |  |  |  |  |  |  |  |  |  |  |  |  |  |  |  |
| 142223475 | Fiber/PMT assembly Module #5 |  | 31d | 2013-02-04 A | 2013-02-18 A | 142223470 | 100% |  | 2013-03-28 | 2013-05-09 |  |  |  | CONTRB UNIV LBR [120 h]; PD UNIV STUDNT [120 h]; VISTNG USERS [620 h]; PD UNIV STAFF [292 h] | 30,620.36 | 30,620.36 | 0 | 30620.36 | ELOUADRHIRI L | 1 | 1 | U | LATIFA E | 10-014 | 11-026 | 11 -035 |  | 12-054 | 12-007 | OPC A |  |  |  |  |  |  |  |  |  |  |  |  |  |  |  |  |  |  |
| 142223465 | Setup module5 |  | 6d | 2013-02-05 A | 2013-02-12 A | 142223295, 142223460 | 100% |  | 2013-03-05 | 2013-03-12 |  |  |  | CONTRB UNIV LBR [40 h]; MECH TECH [24 h]; VISTNG USERS [48 h]; PD UNIV STUDNT [40 h] | 2,498.64 | 2,498.64 | 0 | 2498.64 | ELOUADRHIRI L | 1 | 1 | H | LATIFA E | 10-014 | 11-026 | 11 -035 |  | 12-054 | 12-007 | OPC A |  |  |  |  |  |  |  |  |  |  |  |  |  |  |  |  |  |  |
| 142223305 | Assembly of box 6 |  | 10d | 2013-02-11 A | 2013-03-12 A | 142223300 FS-10d | 100% |  | 2013-03-28 | 2013-04-10 |  |  |  | CONTRB UNIV LBR [40 h]; VISTNG USERS [88 h]; MECH TECH [88 h]; PD UNIV STUDNT [40 h] | 6,231.68 | 6,231.68 | 0 | 6231.68 | ELOUADRHIRI L | 1 | 1 | H | LATIFA E | 10-014 | 11-026 | 11 -035 |  | 12-054 | 12-007 | OPC A |  |  |  |  |  |  |  |  |  |  |  |  |  |  |  |  |  |  |
| 142223480 | Prepare #5 for test |  | 11d | 2013-02-11 A | 2013-03-15 A | 142223475 | 100% |  | 2013-05-10 | 2013-05-24 |  |  |  | CONTRB UNIV LBR [40 h]; VISTNG USERS [88 h]; PD UNIV STUDNT [40 h] | 2,196 | 2,196 | 0 | 2196 | ELOUADRHIRI L | 1 | 1 | H | LATIFA E | 10-014 | 11-026 | 11 -035 |  | 12-054 | 12-007 | OPC A |  |  |  |  |  |  |  |  |  |  |  |  |  |  |  |  |  |  |
| 142223470 | Prepare components |  | 11d | 2013-02-13 A | 2013-02-27 A | 142223465 | 100% |  | 2013-03-13 | 2013-03-27 |  |  |  | CONTRB UNIV LBR [38 h]; MECH TECH [44 h]; PD UNIV STUDNT [40 h]; VISTNG USERS [88 h] | 4,213.84 | 4,213.84 | 0 | 4213.84 | ELOUADRHIRI L | 1 | 1 | H | LATIFA E | 10-014 | 11-026 | 11 -035 |  | 12-054 | 12-007 | OPC A |  |  |  |  |  |  |  |  |  |  |  |  |  |  |  |  |  |  |
| 142223310 | Stacking #6 |  | 65d | 2013-03-11 A | 2013-05-13 A | 142223305 | 100% |  | 2013-04-15 | 2013-07-16 |  |  |  | PD UNIV STUDNT [88 h]; PD UNIV STAFF [388 h]; CONTRB UNIV LBR [80 h]; VISTNG USERS [812 h]; MECH TECH [240 h] | 50,670.92 | 50,670.92 | 0 | 50670.92 | ELOUADRHIRI L | 1 | 1 | U | LATIFA E | 10-014 | 11-026 | 11 -035 |  | 12-054 | 12-007 | OPC A |  |  |  |  |  |  |  |  |  |  |  |  |  |  |  |  |  |  |
| 142223485 | Testing #5 |  | 11d | 2013-03-16 A | 2013-05-13 A | 142223480 | 100% |  | 2013-04-16 | 2013-04-30 |  |  |  | PD UNIV STAFF [88 h]; VISTNG USERS [88 h]; CONTRB UNIV LBR [88 h] | 6,857.84 | 6,857.84 | 0 | 6857.84 | ELOUADRHIRI L | 1 | 1 | H | LATIFA E | 10-014 | 11-026 | 11 -035 |  | 12-054 | 12-007 | OPC A |  |  |  |  |  |  |  |  |  |  |  |  |  |  |  |  |  |  |
| 142223490 | Disassemble #5 |  | 6d | 2013-05-13 A | 2013-06-10 A | 142223485 | 100% |  | 2013-06-18 | 2013-06-25 |  |  |  | CONTRB UNIV LBR [40 h]; PD UNIV STUDNT [40 h]; VISTNG USERS [48 h] | 1,398 | 1,398 | 0 | 1398 | ELOUADRHIRI L | 1 | 1 | H | LATIFA E | 10-014 | 11-026 | 11 -035 |  | 12-054 | 12-007 | OPC A |  |  |  |  |  |  |  |  |  |  |  |  |  |  |  |  |  |  |
| 142223315 | Close Module 6 |  | 6d | 2013-05-21 A | 2013-05-30 A | 142223310 | 100% |  | 2013-06-21 | 2013-06-28 |  |  |  | CONTRB UNIV LBR [33.6 h]; VISTNG USERS [48 h]; MECH TECH [48 h]; PD UNIV STUDNT [40 h] | 3,599.28 | 3,599.28 | 0 | 3599.28 | ELOUADRHIRI L | 1 | 1 | H | LATIFA E | 10-014 | 11-026 | 11 -035 |  | 12-054 | 12-007 | OPC A |  |  |  |  |  |  |  |  |  |  |  |  |  |  |  |  |  |  |
| 142223495 | Move #5 to storage |  | 2d | 2013-06-17 A | 2013-06-21 A | 142223490 | 100% |  | 2013-07-17 | 2013-07-18 |  |  |  | MECH TECH [16 h] | 733.76 | 733.76 | 0 | 733.76 | ELOUADRHIRI L | 1 | 1 | H | LATIFA E | 10-014 | 11-026 | 11 -035 |  | 12-054 | 12-007 | OPC A |  |  |  |  |  |  |  |  |  |  |  |  |  |  |  |  |  |  |
| 142223500 | Setup module 6 |  | 6d | 2013-06-17 A | 2013-06-21 A | 142223315, 142223495 FS-20d | 100% |  | 2013-06-13 | 2013-06-20 |  |  |  | CONTRB UNIV LBR [40 h]; VISTNG USERS [48 h]; PD UNIV STUDNT [40 h]; MECH TECH [24 h] | 2,498.64 | 2,498.64 | 0 | 2498.64 | ELOUADRHIRI L | 1 | 1 | H | LATIFA E | 10-014 | 11-026 | 11 -035 |  | 12-054 | 12-007 | OPC A |  |  |  |  |  |  |  |  |  |  |  |  |  |  |  |  |  |  |
| 142223505 | Prepare components |  | 11d | 2013-06-17 A | 2013-06-21 A | 142223500 | 100% |  | 2013-07-29 | 2013-08-12 |  |  |  | CONTRB UNIV LBR [40 h]; VISTNG USERS [88 h]; PD UNIV STUDNT [40 h]; MECH TECH [44 h] | 4,213.84 | 4,213.84 | 0 | 4213.84 | ELOUADRHIRI L | 1 | 1 | H | LATIFA E | 10-014 | 11-026 | 11 -035 |  | 12-054 | 12-007 | OPC A |  |  |  |  |  |  |  |  |  |  |  |  |  |  |  |  |  |  |
| 142223510 | Fiber/PMT assembly Module #6 |  | 31d | 2013-06-17 A | 2013-06-21 A | 142223505 | 100% |  | 2013-08-13 | 2013-09-25 |  |  |  | CONTRB UNIV LBR [120 h]; VISTNG USERS [620 h]; PD UNIV STUDNT [120 h]; PD UNIV STAFF [292 h] | 30,620.36 | 30,620.36 | 0 | 30620.36 | ELOUADRHIRI L | 1 | 1 | U | LATIFA E | 10-014 | 11-026 | 11 -035 |  | 12-054 | 12-007 | OPC A |  |  |  |  |  |  |  |  |  |  |  |  |  |  |  |  |  |  |
| 142223515 | Prepare #6 for test |  | 11d | 2013-06-17 A | 2013-06-21 A | 142223510 | 100% |  | 2013-09-26 | 2013-10-10 |  |  |  | CONTRB UNIV LBR [40 h]; PD UNIV STUDNT [40 h]; VISTNG USERS [88 h] | 2,247.14 | 2,196 | 0 | 598.932851 | ELOUADRHIRI L | 1 | 1 | H | LATIFA E | 10-014 | 11-026 | 11 -035 |  | 12-054 | 12-007 | OPC A |  |  |  |  |  |  |  |  |  |  |  |  |  |  |  |  |  |  |
| 142223530 | Move #6 to storage |  | 2d | 2013-06-17 A | 2013-06-21 A |  | 100% |  | 2013-11-05 | 2013-11-06 |  |  |  | MECH TECH [16 h] | 757.12 | 733.76 | 0 | 0 | ELOUADRHIRI L | 1 | 1 | H | LATIFA E | 10-014 | 11-026 | 11 -035 |  | 12-054 | 12-007 | OPC A |  |  |  |  |  |  |  |  |  |  |  |  |  |  |  |  |  |  |
| 142223560 | Store module #5 |  | 1d | 2013-08-30 A | 2013-08-30 A | 142223495, 142223555 | 100% |  | 2013-09-03 | 2013-09-03 |  |  |  |  |  |  |  | 0 | ELOUADRHIRI L | 1 | 1 | Z | LATIFA E | 10-014 | 11-026 | 11 -035 |  | 12-054 | 12-007 | OPC A |  |  |  |  |  |  |  |  |  |  |  |  |  |  |  |  |  |  |
| 142223575 | Re-Baseline Actuals Adjustment |  | 1d | 2013-08-30 A | 2013-08-30 A |  | 100% |  | 2013-09-03 | 2013-09-03 |  |  |  | PROCUREMENT>$50K 69 NO ESCALATION | 128,199.08 |  |  | 128199.08 |  |  |  |  |  |  |  |  |  |  |  |  |  |  |  | 0 | 128199.08 | 12819908 | 100 | ADJ |  |  |  |  |  |  |  |  |  |  |
| 242223312 | Procured Labor for Modules 5 & 6 |  | 39d | 2013-09-03 A | 2013-10-21 A | 9-130M FS+228d | 100% |  | 2013-10-01 | 2013-11-22 |  |  | 8/5 M-F w/JLAB Holidays ReBaseline | PROCUREMENT<$50K 60 NO ESCALATION FY14 | 4,374.99 |  |  | 1093.7475 | ELOUADRHIRI L | 1 | 1 | U | LATIFA E | 10-014 | 11-026 | 11 -035 |  | 12-054 | 12-007 |  |  |  |  | 0 | 4374.99 | 437499 | 100 |  | 242223312 | 3281.2425 | 13-002F | 13-010 | OB | PE | 13-015 | PR | OB |  |
| 242223520 | Testing #6 FY13 |  | 30d | 2013-09-03 A | 2013-10-21 A | 9-130M FS+228d | 100% |  | 2013-10-01 | 2013-11-11 |  |  | 8/5 M-F w/JLAB Holidays ReBaseline | PD UNIV STAFF [106.67 h]; VISTNG USERS [26.67 h]; CONTRB UNIV LBR [29.33 h] | 6,931.08 | 6,840.64 |  | 1679.1677345 | ELOUADRHIRI L | 1 | 1 | U | LATIFA E | 10-014 | 11-026 | 11 -035 |  | 12-054 | 12-007 |  |  |  |  |  |  |  |  |  | 242223520 | 5037.5032035 | 13-002F | 13-010 |  | PE | 13-015 | PR |  |  |
| 242223520a | Testing #6 FY14 |  | 10d | 2013-09-03 A | 2013-10-21 A | 242223520 FS-20d | 100% |  | 2013-10-01 | 2013-10-14 |  |  | 8/5 M-F w/JLAB Holidays ReBaseline | PD UNIV STAFF [53.33 h]; VISTNG USERS [13.33 h]; CONTRB UNIV LBR [14.67 h] | 3,465.32 | 3,424.87 |  | 866.33116725 | ELOUADRHIRI L | 1 | 1 | U | LATIFA E | 10-014 | 11-026 | 11 -035 |  | 12-054 | 12-007 |  |  |  |  |  |  |  |  |  | 242223520 | 2598.99350175 | 13-002F | 13-010 |  | PE | 13-015 | PR |  | 14-001 |
| 242223575 | Forklift Rental for ESB |  | 43d | 2013-09-03 A | 2013-12-05 | 9-130M FS+228d |  | 23d | 2013-10-01 | 2013-12-02 | 505d | 598d | 8/5 M-F w/JLAB Holidays ReBaseline | PROCUREMENT<$50K 60 NO ESCALATION FY14 | 816.67 |  |  | 0 | ELOUADRHIRI L | 1 | 1 | U | LATIFA E | 10-014 | 11-026 | 11 -035 |  |  | 12-007 |  |  |  | 11-038 | 816.67 | 0 | 0 | 100 |  | 242223575 |  | 13-002F | 13-010 | OB |  | 13-015 | PR | OB |  |
| 242223525 | Disassemble #6 |  | 6d | 2013-10-01 A | 2013-10-21 A | 242223520a, 242223520 | 100% |  | 2013-11-15 | 2013-11-22 |  |  | 8/5 M-F w/JLAB Holidays ReBaseline | CONTRB UNIV LBR [40 h]; VISTNG USERS [80 h] | 1,647.2 | 1,647.2 |  | 1647.2 | ELOUADRHIRI L | 1 | 1 | H | LATIFA E | 10-014 | 11-026 | 11 -035 |  | 12-054 | 12-007 |  |  |  |  |  |  |  |  |  | 242223525 |  | 13-002F | 13-010 |  | PE | 13-015 | PR |  | 14-001 |
| 242223530 | Move #6 to storage |  | 2d | 2013-10-01 A | 2013-10-21 A | 242223525 | 100% |  | 2013-11-25 | 2013-11-26 |  |  | 8/5 M-F w/JLAB Holidays ReBaseline | MECH TECH [40 h] | 1,892.8 | 1,892.8 |  | 1892.8 | ELOUADRHIRI L | 1 | 1 | H | LATIFA E | 10-014 | 11-026 | 11 -035 |  | 12-054 | 12-007 |  |  |  |  |  |  |  |  |  | 242223530 |  | 13-002F |  |  | PE | 13-015 | PR |  | 14-001 |
| 242223562 | Store module #6 |  | 1d | 2013-10-01 A | 2013-10-21 A | 242223530 | 100% |  | 2013-11-27 | 2013-11-27 |  |  | 8/5 M-F w/JLAB Holidays ReBaseline |  |  |  |  | 0 | ELOUADRHIRI L | 1 | 1 | Z | LATIFA E | 10-014 | 11-026 | 11 -035 |  | 12-054 | 12-007 |  |  |  |  |  |  |  |  |  | 242223562 |  | 13-002F |  |  |  | 13-015 | PR |  |  |
| 242223563M | PCAL Complete | milestone | 0d | 2013-10-21 A | 2013-10-21 A | 242223562, 242223312 | 100% |  | 2013-12-04 | 2013-12-04 |  |  | 8/5 M-F w/JLAB Holidays ReBaseline |  |  |  |  | 0 | ELOUADRHIRI L | 1 | 1 | M | LATIFA E | 10-014 | 11-026 | 11 -035 |  | 12-054 | 12-007 |  |  |  |  |  |  |  |  |  | 242223563M |  | 13-002F |  |  |  | 13-015 | PR |  |  |
| 242223570 | Repair Calorimeter PMT's |  | 172d | 2014-03-04 | 2014-11-03 | 9-140M FS+100d |  |  |  |  | 280d | 373d | 8/5 M-F w/JLAB Holidays ReBaseline | PROCUREMENT<$50K 60 NO ESCALATION FY15 | 10,319 |  |  | 0 | ELOUADRHIRI L | 1 | 1 | U | LATIFA E | 10-014 | 11-026 | 11 -035 |  |  | 12-007 |  |  |  | 11-038 | 10319 | 0 | 0 | 100 |  | 242223570 |  | 13-002F | 13-010 | PE |  | 13-015 | PR |  | 14-001 |

| ID | WBS | Activity | Type | Duration | Start | Finish | Predecessors | Complete | Planned start | Planned finish | Resources | Cost | Actual cost | Remaining Material Cost Based on % Compl | Claimed Material Cost Based on % Complet | Initial Claimed Material Calc | Claimed Material Divider | Calculated Remaining Total Cost | MONTHLY EV COST | RESP - Responsibility | STRT%COMP for CM EVM | FNSH%COMP for CM EVM | EVMS Reporting Codes | CAM RESPONSIBLE | CR 10-060 | CR 11-026 | CR 12-007 | LOE % Pre Calc | LOE % | LOE Divider | LOE Multiplier | CR 07-024 | CR 12-054 | PHAS - Project Phase | CR 09-030 Repair | CR 12-053 | CR 08-016 | CR 09-012 | Profile change | CR 10-026 | OPC Allison | Activities with Steps | CR 12-027 | MARCH!!! |
| --- | --- | --- | --- | --- | --- | --- | --- | --- | --- | --- | --- | --- | --- | --- | --- | --- | --- | --- | --- | --- | --- | --- | --- | --- | --- | --- | --- | --- | --- | --- | --- | --- | --- | --- | --- | --- | --- | --- | --- | --- | --- | --- | --- | --- |
|  | 3 | **1.4.2.2.3 TIME OF FLIGHT** |  |  | 2009-10-06 | 2015-08-04 |  |  |  |  |  |  |  |  |  |  |  |  |  |  |  |  |  |  |  |  |  |  |  |  |  |  |  |  |  |  |  |  |  |  |  |  |  |  |
|  | 1 | **1.4.2.2.3.1 CENTRAL TOF** |  |  | 2010-07-12 | 2015-08-04 |  |  |  |  |  |  |  |  |  |  |  |  |  |  |  |  |  |  |  |  |  |  |  |  |  |  |  |  |  |  |  |  |  |  |  |  |  |  |
| 142231014 |  | CTOF Prepare Mezzanine workspace |  | 113d | 2010-07-12 A | 2010-12-20 A | 9-100M FS+184d | 100% |  |  | PROCUREMENT>$50K 69 NO ESCALATION FY11; PROCUREMENT<$50K 60 NO ESCALATION FY11 | 70,000 |  | 0 | 70000 | 7000000 | 100 | 0 | 70000 | ELOUADRHIRI L | 1 | 1 | D | LATIFA E | 10-060 | 11-026 | 12-007 |  |  |  |  |  |  |  |  |  |  |  |  |  |  |  |  |  |
| 142231005 |  | CTOF-P-#1 Prcrmnt of PMTs & Hi Voltage Dividers |  | 19d | 2011-02-01 A | 2011-02-28 A | 12222045, 12222055, 9-110M, 12222055b, 1132905 | 100% |  |  |  |  |  |  |  |  |  |  | 0 | ELOUADRHIRI L | 1 | 1 | Z | LATIFA E |  | 11-026 | 12-007 |  |  |  |  |  |  |  |  |  |  |  |  |  |  |  |  |  |
| 142231015 |  | CTOF-P-#1 Prcrmnt of Scintillators & Readout Sys |  | 19d | 2011-02-01 A | 2011-02-28 A | 12222055, 12222055b, 9-110M | 100% |  |  |  |  |  |  |  |  |  |  | 0 | ELOUADRHIRI L | 1 | 1 | Z | LATIFA E |  | 11-026 | 12-007 |  |  |  |  |  |  |  |  |  |  |  |  |  |  |  |  |  |
| 142231012E |  | CTOF-FY12 Travel |  | 247d | 2011-10-03 A | 2012-09-28 A | 9-120M | 100% |  |  | TRAVEL | 5,850.04 |  |  |  |  |  | 0 | 5850.04 | ELOUADRHIRI L | 1 | 1 | E | LATIFA E |  |  | 12-007 | 7.69230769 | 92.3076923 | 100 | 100 | 07-024 |  |  |  |  |  |  |  |  |  |  |  |  |
| 142231018M |  | CTOF Start Milestone | milestone | 0d | 2011-11-01 A | 2011-11-01 A | 9-120M FS+21d | 100% | 2011-12-01 | 2011-12-01 |  |  |  |  |  |  |  |  | 0 | ELOUADRHIRI L | 1 | 1 | M | LATIFA E |  | 11-026 | 12-007 |  |  |  |  |  | 12-054F |  |  |  |  |  |  |  |  |  |  |  |
| 142231020 |  | Prepare ALL 30 PR-LETTERS/CONTRACTS |  | 88d | 2011-11-01 A | 2012-03-16 A | 142231018M | 100% | 2011-11-01 | 2012-03-15 | SCIENTIST [180 h] | 12,709.8 | 12,709.8 |  |  |  |  | 0 | 12709.8 | ELOUADRHIRI L | 1 | 1 | H | LATIFA E |  | 11-026 | 12-007 |  |  |  |  |  | 12-054F |  |  |  |  |  |  |  |  |  |  |  |
| 142231140 |  | Final Drawings of Tooling for wrapping |  | 237d | 2011-11-01 A | 2012-10-15 A | 142231018M | 100% |  |  | MECH DES [80 h] | 3,859.32 | 3,859.32 |  |  |  |  | 0 | 3853.6 | ELOUADRHIRI L | 1 | 1 | H | LATIFA E |  | 11-026 | 12-007 |  |  |  |  |  | 12-054F |  |  |  |  |  |  |  |  |  |  |  |
| 142231150 |  | Purchase Clamps for Storage/Transport Racks |  | 33d | 2011-11-01 A | 2011-12-19 A | 142231018M | 100% |  |  | MECH DES [8 h]; SCIENTIST [16 h]; SUPPLIES & MATERIALS | 5,259.12 | 1,515.12 |  |  |  |  | 0 | 5259.12 | ELOUADRHIRI L | 1 | 1 | H | LATIFA E |  | 11-026 | 12-007 |  |  |  |  |  | 12-054F |  |  |  |  |  |  |  |  |  |  |  |
| 142231155 |  | Purchase parts for Storage/Transportation racks |  | 33d | 2011-11-01 A | 2011-12-19 A | 142231018M | 100% |  |  | MECH DES [16 h]; SCIENTIST [16 h]; SUPPLIES & MATERIALS | 3,900.48 | 1,900.48 |  |  |  |  | 0 | 3900.48 | ELOUADRHIRI L | 1 | 1 | H | LATIFA E |  | 11-026 | 12-007 |  |  |  |  |  | 12-054F |  |  |  |  |  |  |  |  |  |  |  |
| 142231160 |  | Final Drawings of Storage-Transportation Rack-25 LG |  | 15d | 2011-11-01 A | 2011-11-21 A | 142231018M | 100% |  |  | MECH DES [80 h] | 3,853.6 | 3,853.6 |  |  |  |  | 0 | 3853.6 | ELOUADRHIRI L | 1 | 1 | H | LATIFA E |  | 11-026 | 12-007 |  |  |  |  |  | 12-054F |  |  |  |  |  |  |  |  |  |  |  |
| 142231185 |  | Purchase/Test/Shipping Acr.Rods to Plastic Craft |  | 15d | 2011-11-01 A | 2011-11-21 A | 142231018M | 100% |  |  | SCIENTIST [32 h]; PROCUREMENT<$50K 60 | 18,359.52 | 2,259.52 | 0 | 16100 | 1610000 | 100 | 0 | 18359.52 | ELOUADRHIRI L | 1 | 1 | D | LATIFA E |  | 11-026 | 12-007 |  |  |  |  |  | 12-054F | IN | 09-030 |  |  |  |  |  |  |  |  |  |
| 142231430 |  | Purchase incidentals/tools/material FY12 |  | 532d | 2011-11-01 A | 2013-08-30 A | 142231018M | 100% | 2011-11-01 | 2013-12-30 | SUPPLIES & MATERIALS | 10,195.5 |  |  |  |  |  | 3058.65 | 10195.5 | ELOUADRHIRI L | 1 | 1 | D | LATIFA E |  | 11-026 | 12-007 |  |  |  |  |  |  |  |  | 12-053 |  |  |  |  |  |  |  |  |
| 142231430a |  | Purchase incidentals/tools/material FY13 |  | 532d | 2011-11-01 A | 2013-08-30 A | 142231430 FS-340d | 100% | 2011-11-01 | 2013-12-30 | SUPPLIES & MATERIALS | 10,613.82 |  |  |  |  |  | 4273.458 | 10613.82 | ELOUADRHIRI L | 1 | 1 | D | LATIFA E |  | 11-026 | 12-007 |  |  |  |  |  |  |  |  | 12-053 |  |  |  |  |  |  |  |  |
| 142231170 |  | Fabricate Storage-Transportation Rack-25 DSLG |  | 32d | 2011-11-21 A | 2012-01-16 A | 142231150 FS-60d, 142231155 FS-20d, 142231160 | 100% | 2011-11-21 | 2012-01-13 | MECH TECH [10 h]; SUPPLIES & MATERIALS | 2,444.4 | 444.4 |  |  |  |  | 0 | 2444.4 | ELOUADRHIRI L | 1 | 1 | H | LATIFA E |  | 11-026 | 12-007 |  |  |  |  |  | 12-054F | IN | 09-030 |  |  |  |  |  |  |  |  |  |
| 142231105 |  | Specify the Scintillator Quality |  | 45d | 2011-12-05 A | 2012-02-14 A | 142231018M FS+30d | 100% |  |  | MECH DES [16 h]; SCIENTIST [16 h] | 1,900.48 | 1,900.48 |  |  |  |  | 0 | 1900.48 | ELOUADRHIRI L | 1 | 1 | H | LATIFA E |  | 11-026 | 12-007 |  |  |  |  |  | 12-054F |  |  |  |  |  |  |  |  |  |  |  |
| 142231110 |  | Purchase/Fabrication./Ship. Scintillators |  | 116d | 2011-12-19 A | 2012-06-11 A | 142231020 FS-57d, 142231105 FS-40d | 100% |  |  | SCIENTIST [26 h]; PROCUREMENT<$50K 60; PROCUREMENT>$50K 69 | 61,835.86 | 1,835.86 | 0 | 60000 | 6000000 | 100 | 0 | 61835.86 | ELOUADRHIRI L | 1 | 1 | D | LATIFA E |  | 11-026 | 12-007 |  |  |  |  |  | 12-054F |  |  |  |  |  |  |  |  |  |  |  |
| 142231190 |  | Purchase/Fabrication./Shipping Bent .LG's |  | 294d | 2011-12-19 A | 2012-12-17 A | 142231018M FS+20d, 142231185, 142231180 FS-60d | 100% | 2011-12-19 | 2013-03-01 | SCIENTIST [104 h]; PROCUREMENT<$50K 60; PROCUREMENT>$50K 69 | 77,423.03 | 7,394.39 | 0 | 70000 | 7000000 | 100 | 0 | 77343.44 | ELOUADRHIRI L | 1 | 1 | D | LATIFA E |  | 11-026 | 12-007 |  |  |  |  |  | 12-054F | IN | 09-030 |  |  |  |  |  |  |  |  |  |
| 142231195 |  | Purchase/Fabrication./Shipping Straight .LG's |  | 166d | 2011-12-19 A | 2012-08-20 A | 142231185, 142231175 FS-80d, 142231018M | 100% |  |  | SCIENTIST [104 h]; PROCUREMENT<$50K 60; PROCUREMENT>$50K 69 | 75,843.44 | 7,343.44 | 0 | 68500 | 6850000 | 100 | 0 | 75843.44 | ELOUADRHIRI L | 1 | 1 | D | LATIFA E |  | 11-026 | 12-007 |  |  |  |  |  | 12-054F | IN | 09-030 |  |  |  |  |  |  |  |  |  |
| 142231375 |  | Purchase/Fabricate/Ship PMT+Inner.Magn. Shield |  | 185d | 2011-12-19 A | 2012-09-17 A | 142231018M FS+41d | 100% |  |  | SCIENTIST [7 h]; PROCUREMENT<$50K 60; PROCUREMENT>$50K 69 | 233,494.27 | 494.27 | 0 | 233000 | 23300000 | 100 | 0 | 233494.27 | ELOUADRHIRI L | 1 | 1 | D | LATIFA E |  | 11-026 | 12-007 |  |  |  |  |  |  | IN | 09-030 |  |  |  |  |  |  |  |  |  |
| 142231130 |  | Final Drawings of Precision Gluing Frame-Table |  | 111d | 2012-01-03 A | 2012-06-11 A | 142231018M FS+40d | 100% |  |  | MECH DES [150 h] | 7,225.5 | 7,225.5 |  |  |  |  | 0 | 7225.5 | ELOUADRHIRI L | 1 | 1 | H | LATIFA E |  | 11-026 | 12-007 |  |  |  |  |  | 12-054F |  |  |  | 08-016 | 09-012 |  |  |  |  |  |  |
| 142231165 |  | Fabricate Storage-Transportation Rack-25 USLG |  | 29d | 2012-01-03 A | 2012-02-13 A | 142231155, 142231160, 142231150 | 100% |  |  | MECH TECH [12 h]; SUPPLIES & MATERIALS | 2,533.28 | 533.28 |  |  |  |  | 0 | 2533.28 | ELOUADRHIRI L | 1 | 1 | H | LATIFA E |  | 11-026 | 12-007 |  |  |  |  |  | 12-054F | IN | 09-030 |  |  |  |  |  |  |  |  |  |
| 142231225 |  | Final Drawings of Counter Support Arm Case |  | 200d | 2012-01-03 A | 2012-10-15 A | 142231018M FS+40d | 100% |  |  | MECH DES [150 h] | 7,238.21 | 7,238.21 |  |  |  |  | 0 | 7225.5 | ELOUADRHIRI L | 1 | 1 | H | LATIFA E |  | 11-026 | 12-007 |  |  |  |  |  |  |  |  |  | 08-016 | 09-012 | C | 10-026 |  |  |  |  |
| 142231280 |  | Final Drawings of Magnetic Shield Compensating Coil |  | 289d | 2012-01-03 A | 2013-08-30 A | 142231018M FS+40d | 100% | 2012-01-03 | 2013-03-01 | MECH DES [80 h] | 3,896.23 | 3,920.96 |  |  |  |  | 1926.8 | 3853.6 | ELOUADRHIRI L | 1 | 1 | H | LATIFA E |  | 11-026 | 12-007 |  |  |  |  |  |  | IN | 09-030 |  |  |  |  |  |  |  |  |  |
| 142231285 |  | Final Drawings of Magnetic Shield Components |  | 200d | 2012-01-03 A | 2012-10-15 A | 142231018M FS+40d | 100% |  |  | MECH DES [150 h] | 7,238.21 | 7,238.21 |  |  |  |  | 0 | 7225.5 | ELOUADRHIRI L | 1 | 1 | H | LATIFA E |  | 11-026 | 12-007 |  |  |  |  |  |  | IN | 09-030 |  |  |  |  |  |  |  |  |  |
| 142231300 |  | Purchase/Fabricate/Ship Middle.Magn. Shield FY12 |  | 358d | 2012-01-03 A | 2013-01-21 A | 142231285 FS-80d | 100% | 2012-01-03 | 2013-06-07 | SCIENTIST [4.92 h] | 352.63 | 350.45 |  |  |  |  | 0 | 347.4012 | ELOUADRHIRI L | 1 | 1 | D | LATIFA E |  | 11-026 | 12-007 |  |  |  |  |  |  | IN | 09-030 | 12-053 |  |  |  |  | OPC A |  |  |  |
| 142231300a |  | Purchase/Fabricate/Ship Middle.Magn. Shield FY13 |  | 358d | 2012-01-03 A | 2013-01-21 A | 142231300 FS-130d | 100% | 2012-01-03 | 2013-06-10 | SCIENTIST [1.08 h] | 77.41 | 76.93 |  |  |  |  | 0 | 78.6888 | ELOUADRHIRI L | 1 | 1 | D | LATIFA E |  | 11-026 | 12-007 |  |  |  |  |  |  | IN | 09-030 | 12-053 |  |  |  |  |  |  |  |  |
| 142231300b |  | Purchase/Fabricate/Ship Middle.Magn. Shield Procurement |  | 358d | 2012-01-03 A | 2013-01-21 A | 142231285 FS-80d | 100% | 2012-01-03 | 2013-06-07 | PROCUREMENT<$50K 60 NO ESCALATION FY13 | 29,500 |  | 0 | 29500 | 2950000 | 100 | 0 | 29500 | ELOUADRHIRI L | 1 | 1 | D | LATIFA E |  | 11-026 | 12-007 |  |  |  |  |  |  | IN | 09-030 | 12-053 |  |  |  |  |  |  |  |  |
| 142231305 |  | Purchase/Fabricate/Ship Middle. Magn. Disks FY12 |  | 358d | 2012-01-03 A | 2013-01-21 A | 142231285 FS-80d | 100% | 2012-01-03 | 2013-06-07 | SCIENTIST [4.92 h] | 352.63 | 350.45 |  |  |  |  | 0 | 347.4012 | ELOUADRHIRI L | 1 | 1 | D | LATIFA E |  | 11-026 | 12-007 |  |  |  |  |  |  | IN | 09-030 | 12-053 |  |  |  |  | OPC A |  |  |  |
| 142231305a |  | Purchase/Fabricate/Ship Middle. Magn. Disks FY13 |  | 358d | 2012-01-03 A | 2013-01-21 A | 142231305 FS-130d | 100% | 2012-01-03 | 2013-06-10 | SCIENTIST [1.08 h] | 77.41 | 76.93 |  |  |  |  | 0 | 78.6888 | ELOUADRHIRI L | 1 | 1 | D | LATIFA E |  | 11-026 | 12-007 |  |  |  |  |  |  | IN | 09-030 | 12-053 |  |  |  |  |  |  |  |  |
| 142231305b |  | Purchase/Fabricate/Ship Middle. Magn. Disks Procurement |  | 358d | 2012-01-03 A | 2013-01-21 A | 142231285 FS-80d | 100% | 2012-01-03 | 2013-06-07 | PROCUREMENT<$50K 60 NO ESCALATION FY13 | 17,200 |  | 0 | 17200 | 1720000 | 100 | 0 | 17200 | ELOUADRHIRI L | 1 | 1 | D | LATIFA E |  | 11-026 | 12-007 |  |  |  |  |  |  | IN | 09-030 | 12-053 |  |  |  |  |  |  |  |  |
| 142231310 |  | Purchase/Fabricate/Ship Inner. Magn. Disks FY12 |  | 358d | 2012-01-03 A | 2013-02-25 A | 142231285 FS-80d | 100% | 2012-01-03 | 2013-06-07 | SCIENTIST [4.92 h] | 352.63 | 351.11 |  |  |  |  | 0 | 347.4012 | ELOUADRHIRI L | 1 | 1 | D | LATIFA E |  | 11-026 | 12-007 |  |  |  |  |  |  | IN | 09-030 | 12-053 |  |  |  |  | OPC A |  |  |  |
| 142231310a |  | Purchase/Fabricate/Ship Inner. Magn. Disks FY13 |  | 358d | 2012-01-03 A | 2013-02-25 A | 142231310 FS-130d | 100% | 2012-01-03 | 2013-06-10 | SCIENTIST [1.08 h] | 77.41 | 77.07 |  |  |  |  | 0 | 78.6888 | ELOUADRHIRI L | 1 | 1 | D | LATIFA E |  | 11-026 | 12-007 |  |  |  |  |  |  | IN | 09-030 | 12-053 |  |  |  |  |  |  |  |  |
| 142231310b |  | Purchase/Fabricate/Ship Inner. Magn. Disks Procurement |  | 358d | 2012-01-03 A | 2013-08-30 A | 142231285 FS-80d | 100% | 2012-01-03 | 2013-06-07 | PROCUREMENT<$50K 60 NO ESCALATION FY13 | 11,300 |  | 0 | 11300 | 1130000 | 100 | 8475 | 11300 | ELOUADRHIRI L | 1 | 1 | D | LATIFA E |  | 11-026 | 12-007 |  |  |  |  |  |  | IN | 09-030 | 12-053 |  |  |  |  |  |  |  |  |
| 142231330 |  | Purchase/Fabricate/Ship External Magnetic Shields FY12 |  | 219.39d | 2012-01-03 A | 2012-11-12 A | 142231018M FS+43d | 100% |  |  | SCIENTIST [85.28 h] | 6,048.2 | 6,048.2 |  |  |  |  | 0 | 6021.6208 | ELOUADRHIRI L | 1 | 1 | D | LATIFA E |  | 11-026 | 12-007 |  |  |  |  |  |  | IN | 09-030 | 12-053 |  |  |  |  | OPC A |  |  |  |
| 142231330a |  | Purchase/Fabricate/Ship External Magnetic Shields FY13 |  | 220d | 2012-01-03 A | 2012-11-12 A | 142231330 FS-45d | 100% |  |  | SCIENTIST [10.72 h] | 760.34 | 760.34 |  |  |  |  | 0 | 781.0592 | ELOUADRHIRI L | 1 | 1 | D | LATIFA E |  | 11-026 | 12-007 |  |  |  |  |  |  | IN | 09-030 | 12-053 |  |  |  |  |  |  |  |  |
| 142231330b |  | Purchase/Fabricate/Ship External Magnetic Shields Procurement |  | 220d | 2012-01-03 A | 2012-11-12 A | 142231018M FS+43d | 100% |  |  | PROCUREMENT<$50K 60 NO ESCALATION FY13 | 36,100 |  | 0 | 36100 | 3610000 | 100 | 0 | 36100 | ELOUADRHIRI L | 1 | 1 | D | LATIFA E |  | 11-026 | 12-007 |  |  |  |  |  |  | IN | 09-030 | 12-053 |  |  |  |  |  |  |  |  |
| 142231200 |  | Purchase buffing tools and materials |  | 345d | 2012-01-14 A | 2013-08-30 A | 142231018M | 100% | 2012-01-17 | 2013-06-03 | SUPPLIES & MATERIALS; SCIENTIST [32 h] | 3,293.95 | 2,299.76 |  |  |  |  | 1629.76 | 3259.52 | ELOUADRHIRI L | 1 | 1 | H | LATIFA E |  | 11-026 | 12-007 |  |  |  |  |  | 12-054F | IN | 09-030 |  |  |  |  |  |  |  |  |  |
| 142231175 |  | Shipping Racks to Company USLG |  | 10d | 2012-02-06 A | 2012-02-20 A | 142231165 | 100% | 2012-02-06 | 2012-02-17 | MECH TECH [16 h]; SUPPLIES & MATERIALS; SCIENTIST [3 h]; SKLLD TRADE [16 h] | 2,458.07 | 1,458.07 |  |  |  |  | 0 | 2458.07 | ELOUADRHIRI L | 1 | 1 | H | LATIFA E |  | 11-026 | 12-007 |  |  |  |  |  | 12-054F | IN | 09-030 |  |  |  |  |  |  |  |  |  |
| 142231180 |  | Shipping Racks to Company DSLG |  | 10d | 2012-02-06 A | 2012-02-20 A | 142231170, 142231175 FS-15d | 100% | 2012-02-06 | 2012-02-17 | MECH TECH [16 h]; SUPPLIES & MATERIALS; SCIENTIST [3 h]; SKLLD TRADE [16 h] | 2,458.07 | 1,458.07 |  |  |  |  | 0 | 2458.07 | ELOUADRHIRI L | 1 | 1 | H | LATIFA E |  | 11-026 | 12-007 |  |  |  |  |  | 12-054F | IN | 09-030 |  |  |  |  |  |  |  |  |  |
| 142231145 |  | Fabricate Tooling for Wrapping |  | 261d | 2012-02-13 A | 2013-08-30 A | 142231140 FS-30d | 100% | 2012-02-13 | 2013-03-01 | MSHOP; MECH TECH [20 h]; SCIENTIST [20 h]; SKLLD TRADE [20 h] | 5,006.32 | 3,025.57 |  |  |  |  | 2485 | 4970 | ELOUADRHIRI L | 1 | 1 | H | LATIFA E |  | 11-026 | 12-007 |  |  |  |  |  | 12-054F |  |  |  |  |  |  |  |  |  |  |  |
| 142231210 |  | Purchase TEDLAR for wrapping |  | 11d | 2012-03-02 A | 2012-03-19 A | 142231018M FS+95d | 100% | 2012-03-02 | 2012-03-16 | SUPPLIES & MATERIALS; SCIENTIST [17 h] | 2,200.37 | 1,200.37 |  |  |  |  | 0 | 2200.37 | ELOUADRHIRI L | 1 | 1 | H | LATIFA E |  | 11-026 | 12-007 |  |  |  |  |  | 12-054F | IN | 09-030 |  |  |  |  |  |  |  |  |  |
| 142231235 |  | Final Drawings of Counter Storage-25 Armed Counters |  | 16d | 2012-03-02 A | 2012-03-26 A | 142231018M FS+40d, 9-120M FS+100d | 100% | 2012-03-02 | 2012-03-23 | MECH DES [80 h] | 3,853.6 | 3,853.6 |  |  |  |  | 0 | 3853.6 | ELOUADRHIRI L | 1 | 1 | H | LATIFA E |  | 11-026 | 12-007 |  |  |  |  |  |  |  |  |  |  |  |  |  |  |  |  |  |
| 142231260 |  | Final Drawings of CTOF Support and Solenoid Harness |  | 248d | 2012-03-02 A | 2013-08-30 A | 142231018M FS+80d | 100% | 2012-03-02 | 2013-03-01 | MECH DES [200 h] | 9,758.19 | 9,820.77 |  |  |  |  | 4817 | 9634 | ELOUADRHIRI L | 1 | 1 | H | LATIFA E |  | 11-026 | 12-007 |  |  |  |  |  |  |  |  |  |  |  |  |  |  |  |  |  |
| 142231270 |  | Final Drawings of Counter installation Arm-Cart |  | 248d | 2012-03-02 A | 2013-08-30 A | 142231018M FS+80d | 100% | 2012-03-02 | 2013-03-01 | MECH DES [200 h] | 9,758.19 | 9,820.77 |  |  |  |  | 4817 | 9634 | ELOUADRHIRI L | 1 | 1 | H | LATIFA E |  | 11-026 | 12-007 |  |  |  |  |  | 12-054F |  |  |  |  |  |  |  |  |  |  |  |
| 142231120 |  | Purchase OMNICURE S2000 UV Curing system |  | 26d | 2012-04-09 A | 2012-05-14 A | 142231018M | 100% |  |  | SCIENTIST [4 h]; SUPPLIES & MATERIALS | 6,782.44 | 282.44 |  |  |  |  | 0 | 6782.44 | ELOUADRHIRI L | 1 | 1 | D | LATIFA E |  | 11-026 | 12-007 |  |  |  |  |  | 12-054F |  |  |  |  |  |  |  |  |  |  |  |
| 142231240 |  | Fabricate Storage Racks-25 Armed Counters FY12 |  | 69d | 2012-04-09 A | 2012-07-16 A | 142231150, 142231235, 142231155 | 100% |  |  | MECH TECH [39.72 h]; SKLLD TRADE [34.76 h]; SCIENTIST [3.97 h] | 3,208.2 | 3,208.2 |  |  |  |  | 0 | 3208.2005 | ELOUADRHIRI L | 1 | 1 | H | LATIFA E |  | 11-026 | 12-007 |  |  |  |  |  |  | IN | 09-030 | 12-053 |  |  |  |  | OPC A |  |  |  |
| 142231240a |  | Fabricate Storage Racks-25 Armed Counters FY13 |  | 69d | 2012-04-09 A | 2012-07-16 A | 142231240 | 100% |  |  | MECH TECH [0.28 h]; SKLLD TRADE [0.24 h]; SCIENTIST [0.03 h] | 22.59 | 22.59 |  |  |  |  | 0 | 23.3114 | ELOUADRHIRI L | 1 | 1 | H | LATIFA E |  | 11-026 | 12-007 |  |  |  |  |  |  | IN | 09-030 | 12-053 |  |  |  |  |  |  |  |  |
| 142231380 |  | Testing the PMT timing performance FY12 |  | 152.5d | 2012-04-09 A | 2012-11-12 A | 142231375 FS-110d | 100% |  |  | SCIENTIST [58.6 h]; CONTRB UNIV LBR [1214.25 h] | 4,164.12 | 4,164.12 |  |  |  |  | 0 | 4137.746 | ELOUADRHIRI L | 1 | 1 | U | LATIFA E |  | 11-026 | 12-007 |  |  |  |  |  |  | IN | 09-030 | 12-053 |  |  |  |  |  |  |  |  |
| 142231380a |  | Testing the PMT timing performance FY13 |  | 153d | 2012-04-09 A | 2012-11-12 A | 142231380 FS-25d | 100% |  |  | SCIENTIST [24.41 h]; CONTRB UNIV LBR [505.94 h] | 1,734.72 | 1,734.72 |  |  |  |  | 0 | 1778.5126 | ELOUADRHIRI L | 1 | 1 | U | LATIFA E |  | 11-026 | 12-007 |  |  |  |  |  |  | IN | 09-030 | 12-053 |  |  |  |  |  |  |  |  |
| 142231125 |  | Purchase UV Glue, Tooling and Materials |  | 271d | 2012-05-01 A | 2013-08-30 A | 142231018M | 100% | 2012-05-01 | 2013-06-03 | SUPPLIES & MATERIALS; SCIENTIST [4 h] | 3,287.92 | 288.58 |  |  |  |  | 1969.464 | 3282.44 | ELOUADRHIRI L | 1 | 1 | D | LATIFA E |  | 11-026 | 12-007 |  |  |  |  |  | 12-054F |  |  |  |  |  |  |  |  |  |  |  |
| 142231205 |  | Purchase 900 shts, 12 sqin, VM2002, for wrapping |  | 271d | 2012-05-01 A | 2013-08-30 A | 142231018M FS+95d | 100% | 2012-05-01 | 2013-06-03 | SCIENTIST [8 h]; PROCUREMENT<$50K 60 | 16,375.84 | 577.17 | 0 | 15800 | 1580000 | 100 | 4091.22 | 16364.88 | ELOUADRHIRI L | 1 | 1 | D | LATIFA E |  | 11-026 | 12-007 |  |  |  |  |  | 12-054F | IN | 09-030 |  |  |  |  |  |  |  |  |  |
| 142231230 |  | Fabricate Counter-Support-Arm -Case FY12 |  | 206d | 2012-05-01 A | 2013-08-30 A | 142231225 FS-30d | 100% | 2012-05-01 | 2013-03-01 | MECH DES [36.23 h]; MSHOP; MECH TECH [72.45 h]; SCIENTIST [36.23 h]; SKLLD TRADE [235.47 h] | 29,766.75 | 15,735.16 |  |  |  |  | 29527.8489 | 29527.8489 | ELOUADRHIRI L | 1 | 1 | S | LATIFA E |  | 11-026 | 12-007 |  |  |  |  |  |  |  |  | 12-053 | 08-016 | 09-012 | C | 10-026 | OPC A | ST |  |  |
| 142231230a |  | Fabricate Counter-Support-Arm -Case FY13 |  | 206d | 2012-05-01 A | 2013-08-30 A | 142231230 FS-60d | 100% | 2012-05-01 | 2013-03-01 | MECH DES [3.77 h]; MSHOP; MECH TECH [7.55 h]; SCIENTIST [3.77 h]; SKLLD TRADE [24.53 h] | 3,147.39 | 1,638.84 |  |  |  |  | 3173.7575 | 3173.7575 | ELOUADRHIRI L | 1 | 1 | S | LATIFA E |  | 11-026 | 12-007 |  |  |  |  |  |  |  |  | 12-053 | 08-016 | 09-012 | C | 10-026 |  | ST |  |  |
| 142231290 |  | Purchase Coil components and materials |  | 271d | 2012-05-01 A | 2013-08-30 A | 142231280 FS-65d | 100% | 2012-05-01 | 2013-06-03 | SCIENTIST [6 h]; SUPPLIES & MATERIALS | 8,431.88 | 432.88 |  |  |  |  | 4211.83 | 8423.66 | ELOUADRHIRI L | 1 | 1 | H | LATIFA E |  | 11-026 | 12-007 |  |  |  |  |  |  | IN | 09-030 |  |  |  |  |  |  |  |  |  |
| 142231295 |  | Fabricate Compensating Coil FY12 |  | 275d | 2012-05-01 A | 2013-08-30 A | 142231280 FS-60d, 142231290 FS-125d | 100% | 2012-05-01 | 2013-06-07 | MECH TECH [12.35 h]; SKLLD TRADE [41.18 h]; SCIENTIST [12.35 h]; MSHOP | 11,088.57 | 2,859.32 |  |  |  |  | 5516.81925 | 11033.6385 | ELOUADRHIRI L | 1 | 1 | H | LATIFA E |  | 11-026 | 12-007 |  |  |  |  |  |  | IN | 09-030 | 12-053 |  |  |  |  | OPC A |  |  |  |
| 142231295a |  | Fabricate Compensating Coil FY13 |  | 275d | 2012-05-01 A | 2013-08-30 A | 142231295 FS-130d | 100% | 2012-05-01 | 2013-06-07 | SCIENTIST [2.65 h]; MSHOP; MECH TECH [2.65 h]; SKLLD TRADE [8.82 h] | 2,432.68 | 612.99 |  |  |  |  | 1220.0322 | 2440.0644 | ELOUADRHIRI L | 1 | 1 | H | LATIFA E |  | 11-026 | 12-007 |  |  |  |  |  |  | IN | 09-030 | 12-053 |  |  |  |  |  |  |  |  |
| 142231320 |  | Purchase DCPS 200V/17A Ext.Magn. Shield |  | 216d | 2012-05-01 A | 2013-08-30 A | 142231018M FS+10d | 100% | 2012-05-01 | 2013-03-15 | SCIENTIST [32 h]; PROCUREMENT<$50K 60 | 15,298.13 | 2,308.67 | 0 | 13001.94 | 1300194 | 100 | 12266.768 | 15333.46 | ELOUADRHIRI L | 1 | 1 | D | LATIFA E |  | 11-026 | 12-007 |  |  |  |  |  | 12-054F | IN | 09-030 |  |  |  |  |  | OPC A |  | 12-027 |  |
| 142231115 |  | Refurbish Laser Calibration System FY12 |  | 214d | 2012-06-02 A | 2013-08-30 A | 142231105 FS+42d, 9-120M FS+164d | 100% | 2012-06-05 | 2013-04-15 | SUPPLIES & MATERIALS; SKLLD TRADE [9.44 h]; SCIENTIST [23.59 h]; MECH DES [18.87 h]; MECH TECH [23.59 h] | 7,789.93 | 4,030.92 |  |  |  |  | 3856.4777 | 7712.9554 | ELOUADRHIRI L | 1 | 1 | H | LATIFA E |  | 11-026 | 12-007 |  |  |  |  |  |  |  |  | 12-053 |  |  |  |  | OPC A |  |  |  |
| 142231115a |  | Refurbish Laser Calibration System FY13 |  | 214d | 2012-06-02 A | 2013-08-30 A | 142231115 FS-160d | 100% | 2012-06-05 | 2013-04-15 | SCIENTIST [26.41 h]; MECH DES [21.13 h]; MECH TECH [26.41 h]; SKLLD TRADE [10.56 h]; SUPPLIES & MATERIALS | 8,856.32 | 4,512.73 |  |  |  |  | 4455.45435 | 8910.9087 | ELOUADRHIRI L | 1 | 1 | H | LATIFA E |  | 11-026 | 12-007 |  |  |  |  |  |  |  |  | 12-053 |  |  |  |  |  |  |  |  |
| 142231415 |  | Assemble the DAQ system FY12 |  | 213d | 2012-06-03 A | 2013-08-30 A | 9-120M FS+184d, 142231375 FS-120d | 100% | 2012-06-05 | 2013-04-12 | SCIENTIST [38.4 h]; MECH TECH [19.2 h] | 3,634.05 | 3,647.92 |  |  |  |  | 1782.336 | 3564.672 | ELOUADRHIRI L | 1 | 1 | H | LATIFA E |  | 11-026 | 12-007 |  |  |  |  |  |  | IN | 09-030 | 12-053 |  |  |  |  |  |  |  |  |
| 142231415a |  | Assemble the DAQ system FY13 |  | 213d | 2012-06-03 A | 2013-08-30 A | 142231415 FS-160d | 100% | 2012-06-05 | 2013-04-12 | SCIENTIST [41.6 h]; MECH TECH [20.8 h] | 3,936.88 | 3,952.01 |  |  |  |  | 1992.432 | 3984.864 | ELOUADRHIRI L | 1 | 1 | H | LATIFA E |  | 11-026 | 12-007 |  |  |  |  |  |  | IN | 09-030 | 12-053 |  |  |  |  |  |  |  |  |
| 142231135 |  | Fabricate Precision Gluing-Frame-Table |  | 88d | 2012-06-05 A | 2012-10-05 A | 142231130 FS-20d | 100% |  |  | MSHOP | 12,000 |  |  |  |  |  | 0 | 12000 | ELOUADRHIRI L | 1 | 1 | H | LATIFA E |  | 11-026 | 12-007 |  |  |  |  |  | 12-054F | IN | 09-030 |  |  |  |  |  | OPC A |  |  |  |
| 142231325 |  | Assemble the Setup for Magnetic Shields Tests |  | 306d | 2012-06-05 A | 2013-08-30 A | 142231315 FS-220d, 142231320 FS-190d | 100% | 2012-06-05 | 2013-08-23 | SCIENTIST [96 h]; ELEC TECH [48 h]; CONTRB UNIV LBR [1720 h] | 9,103.53 | 9,104.77 |  |  |  |  | 4590.24 | 9180.48 | ELOUADRHIRI L | 1 | 1 | H | LATIFA E |  | 11-026 | 12-007 |  |  |  |  |  | 12-054F | IN | 09-030 |  |  |  |  |  | OPC A |  | 12-027 |  |
| 142231215 |  | Polishing/finishing LG |  | 139d | 2012-07-09 A | 2013-08-30 A | 142231185, 142231200 FS-125d, 142231205 FS-125d, 142231210 FS-34d | 100% | 2012-07-09 | 2013-01-31 | SCIENTIST [40 h]; MECH TECH [320 h]; SUPPLIES & MATERIALS | 20,858.53 | 17,477.69 |  |  |  |  | 14381.64 | 20545.2 | ELOUADRHIRI L | 1 | 1 | U | LATIFA E |  | 11-026 | 12-007 |  |  |  |  |  | 12-054F | IN | 09-030 |  |  |  |  |  | OPC A |  |  | XX |
| 142231245 |  | Two-side glue Counters in Support Arm FY12 |  | 161d | 2012-07-09 A | 2013-08-30 A | 142231190 FS-60d, 142231135 FS-120d, 142231110 FS-10d, 142231125 FS-125d, 142231220 FS-80d, 142231120, 142231195 FS-20d, 142231215 FS-120d | 100% | 2012-07-09 | 2013-03-05 | MECH TECH [12.97 h]; SCIENTIST [12.97 h] | 1,522.35 | 1,530.01 |  |  |  |  | 1417.588575 | 1492.1985 | ELOUADRHIRI L | 1 | 1 | U | LATIFA E |  | 11-026 | 12-007 |  |  |  |  |  | 12-054F |  |  | 12-053 |  |  |  |  | OPC A |  |  |  |
| 142231245a |  | Two-side glue Counters in Support Arm FY13 |  | 161d | 2012-07-09 A | 2013-08-30 A | 142231245 FS-125d | 100% | 2012-07-09 | 2013-03-05 | SCIENTIST [147.03 h]; MECH TECH [147.03 h] | 17,257.66 | 17,344.48 |  |  |  |  | 16582.63152 | 17455.4016 | ELOUADRHIRI L | 1 | 1 | U | LATIFA E |  | 11-026 | 12-007 |  |  |  |  |  | 12-054F |  |  | 12-053 |  |  |  |  |  |  |  |  |
| 142231220 |  | Wrapping and Transmittance test of LG |  | 134d | 2012-08-13 A | 2013-08-30 A | 142231200 FS-125d, 142231145 FS-80d, 142231210 FS-20d, 142231205 FS-125d | 100% | 2012-08-13 | 2013-03-01 | SCIENTIST [52 h]; MECH TECH [120 h]; CONTRB UNIV LBR [1720 h] | 9,218.99 | 9,254.63 |  |  |  |  | 8104.068 | 9004.52 | ELOUADRHIRI L | 1 | 1 | U | LATIFA E |  | 11-026 | 12-007 |  |  |  |  |  | 12-054F |  |  |  |  |  |  |  |  |  |  |  |
| 142231013E |  | CTOF-FY13 Travel |  | 247d | 2012-10-01 A | 2013-08-30 A | 142231012E | 100% | 2012-10-01 | 2013-09-27 | TRAVEL | 5,572.3 |  |  |  |  |  | 1002.08556 | 5572.3 | ELOUADRHIRI L | 1 | 1 | E | LATIFA E |  |  | 12-007 | 7.69230769 | 92.3076923 | 100 | 100 | 07-024 |  |  |  |  |  |  |  |  | OPC A |  |  |  |

Notes:
- 142231230: Steps: Fabricate Counter-Support-Arm -Case FY12 (done)
- 142231230a: Steps: Fabricate Counter-Support-Arm -Case FY13 (done)

| ID | Activity | Duration | Start | Finish | Predecessors | Complete | Remaining | Planned start | Planned finish | Total float | Free float | Calendar | Resources | Cost | Actual cost | Remaining Material Cost Based on % Compl | Claimed Material Cost Based on % Complet | Initial Claimed Material Calc | Claimed Material Divider | Calculated Remaining Total Cost | MONTHLY EV COST | PHAS - Project Phase | RESP - Responsibility | STRT%COMP for CM EVM | FNSH%COMP for CM EVM | EVMS Reporting Codes | CAM RESPONSIBLE | CR 09-030 Repair | CR 11-026 | CR 12-007 | CR 12-027 | OPC Allison | CR 12-054 | CR 12-053 | ReBaseline Actuals Adjustment | LOE Divider | LOE Multiplier | Original Activity ID Rebaseline | PRIOR MONTH EV COST | CR 07-024 | CR 13-002 | BOE Expenses | CR 13-015 | Post Rebaseline | BOE Procurement | BOE Labor | Obligated Prior to Rebaseline | CR 14-001 | Activities with Steps |
| --- | --- | --- | --- | --- | --- | --- | --- | --- | --- | --- | --- | --- | --- | --- | --- | --- | --- | --- | --- | --- | --- | --- | --- | --- | --- | --- | --- | --- | --- | --- | --- | --- | --- | --- | --- | --- | --- | --- | --- | --- | --- | --- | --- | --- | --- | --- | --- | --- | --- |
| 142231315 | Purchase Magnet for Magnetic Shields Tests | 110d | 2013-03-01 A | 2013-03-18 A | 9-130M FS+65d, 142231018M FS+10d | 100% |  | 2013-04-01 | 2013-09-04 |  |  |  | SCIENTIST [48 h]; PROCUREMENT<$50K 60; PROCUREMENT>$50K 69 | 51,578.66 | 3,497.28 | 0 | 48081.38 | 4808138 | 100 | 0 | 51578.66 | IN | ELOUADRHIRI L | 1 | 1 | D | LATIFA E | 09-030 | 11-026 | 12-007 | 12-027 | OPC A | 12-054 |  |  |  |  |  |  |  |  |  |  |  |  |  |  |  |  |
| 142231345 | Final Drawings of Patch Panels for LV & HV;200 ch | 47d | 2013-03-04 A | 2013-08-30 A | 9-120M FS+240d, 142231018M FS+90d, 9-130M FS+81d | 100% |  | 2013-04-01 | 2013-06-05 |  |  |  | ELEC DES [40 h] | 2,084.8 | 2,084.8 |  |  |  |  | 1010.2 | 2020.4 | IN | ELOUADRHIRI L | 1 | 1 | H | LATIFA E | 09-030 | 11-026 | 12-007 |  |  |  |  |  |  |  |  |  |  |  |  |  |  |  |  |  |  |  |
| 142231350 | Final Drawings of Splitter to TDC and ADC; 100 ch | 47d | 2013-03-04 A | 2013-08-30 A | 142231018M FS+90d, 9-120M FS+240d, 9-130M FS+81d | 100% |  | 2013-04-01 | 2013-06-05 |  |  |  | ELEC DES [40 h] | 2,084.8 | 2,084.8 |  |  |  |  | 1010.2 | 2020.4 | IN | ELOUADRHIRI L | 1 | 1 | H | LATIFA E | 09-030 | 11-026 | 12-007 |  |  |  |  |  |  |  |  |  |  |  |  |  |  |  |  |  |  |  |
| 142231250 | Counter-in-rack storage and wrapping | 98d | 2013-08-30 A | 2013-08-30 A | 142231145, 142231195, 142231110 FS-10d, 142231120, 142231125, 142231215, 142231230a, 142231240a, 142231220, 142231190, 142231135 | 100% |  | 2013-10-31 | 2014-03-31 |  |  |  | MECH TECH [104 h]; SCIENTIST [26 h] | 6,875.96 | 6,663.8 |  |  |  |  | 6663.8 | 6663.8 |  | ELOUADRHIRI L | 1 | 1 | U | LATIFA E |  | 11-026 | 12-007 |  | OPC A |  |  |  |  |  |  |  |  |  |  |  |  |  |  |  |  |  |
| 142231255 | Transmittance test of assembled Counters in Rack | 98d | 2013-08-30 A | 2013-08-30 A | 142231220, 142231195, 142231215, 142231230a, 142231135, 142231190, 142231240a, 142231110 FS-10d, 142231120, 142231125 | 100% |  | 2013-10-31 | 2014-03-31 |  |  |  | SCIENTIST [104 h]; CONTRB UNIV LBR [1720 h] | 7,818.72 | 7,577.44 |  |  |  |  | 7577.44 | 7577.44 |  | ELOUADRHIRI L | 1 | 1 | U | LATIFA E |  | 11-026 | 12-007 |  | OPC A |  |  |  |  |  |  |  |  |  |  |  |  |  |  |  |  |  |
| 142231265 | Fabricate Solenoid Harness FY12 | 74d | 2013-08-30 A | 2013-08-30 A | 142231260 | 100% |  | 2013-10-03 | 2014-01-27 |  |  |  | MSHOP; MECH TECH [7.12 h]; SKLLD TRADE [56.92 h] | 7,108 | 2,291.4 |  |  |  |  | 6963.9768 | 6963.9768 |  | ELOUADRHIRI L | 1 | 1 | U | LATIFA E |  | 11-026 | 12-007 |  | OPC A |  | 12-053 |  |  |  |  |  |  |  |  |  |  |  |  |  |  |  |
| 142231265a | Fabricate Solenoid Harness FY13 | 238d | 2013-08-30 A | 2013-08-30 A | 142231265 | 100% |  | 2014-01-28 | 2015-01-12 |  |  |  | MSHOP; MECH TECH [22.88 h]; SKLLD TRADE [183.08 h] | 22,685.61 | 7,369.2 |  |  |  |  | 23112.2884 | 22141.323521 |  | ELOUADRHIRI L | 1 | 1 | U | LATIFA E |  | 11-026 | 12-007 |  |  |  | 12-053 |  |  |  |  |  |  |  |  |  |  |  |  |  |  |  |
| 142231275 | Fabricate Counter-Installation-Arm -Cart | 190d | 2013-08-30 A | 2013-08-30 A | 142231270 FS+120d | 100% |  | 2014-04-03 | 2015-01-08 |  |  |  | MECH TECH [50 h]; SCIENTIST [10 h]; SKLLD TRADE [50 h]; MSHOP | 10,345.4 | 4,747.6 |  |  |  |  | 16098.499633 | 7724.584807 |  | ELOUADRHIRI L | 1 | 1 | H | LATIFA E |  | 11-026 | 12-007 |  | OPC A | 12-054 | 12-053 |  |  |  |  |  |  |  |  |  |  |  |  |  |  |  |
| 142231335 | Purchase Cables and Connectors | 80d | 2013-08-30 A | 2013-08-30 A | 142231018M FS+83d, 9-130M FS+184d, 9-120M FS+205d | 100% |  | 2013-09-03 | 2014-01-02 |  |  |  | SCIENTIST [40 h]; PROCUREMENT<$50K 60 | 29,784 | 2,914.4 | 0 | 26800 | 2680000 | 100 | 29624.4 | 29624.4 | IN | ELOUADRHIRI L | 1 | 1 | D | LATIFA E | 09-030 | 11-026 | 12-007 |  |  |  |  |  |  |  |  |  |  |  |  |  |  |  |  |  |  |  |
| 142231340 | Fabricate Cables LV&HV FY12 | 42d | 2013-08-30 A | 2013-08-30 A | 142231335 | 100% |  | 2014-01-03 | 2014-03-05 |  |  |  | ELEC TECH [33.16 h] | 1,558.19 | 1,510.11 |  |  |  |  | 1463.3508 | 1463.3508 | IN | ELOUADRHIRI L | 1 | 1 | U | LATIFA E | 09-030 | 11-026 | 12-007 |  | OPC A |  | 12-053 |  |  |  |  |  |  |  |  |  |  |  |  |  |  |  |
| 142231340a | Fabricate Cables LV&HV FY13 | 34d | 2013-08-30 A | 2013-08-30 A | 142231340 | 100% |  | 2014-03-06 | 2014-04-22 |  |  |  | ELEC TECH [26.84 h] | 1,261.21 | 1,222.29 |  |  |  |  | 1222.2936 | 1222.2936 | IN | ELOUADRHIRI L | 1 | 1 | U | LATIFA E | 09-030 | 11-026 | 12-007 |  |  |  | 12-053 |  |  |  |  |  |  |  |  |  |  |  |  |  |  |  |
| 142231355 | Fabricate Patch Panels for LV&HV FY12 | 24d | 2013-08-30 A | 2013-08-30 A | 142231350, 142231345 | 100% |  | 2013-10-03 | 2013-11-05 |  |  |  | SKLLD TRADE [7.96 h]; ELEC TECH [15.91 h] | 1,031.15 | 999.32 |  |  |  |  | 968.3703 | 968.3703 | IN | ELOUADRHIRI L | 1 | 1 | H | LATIFA E | 09-030 | 11-026 | 12-007 |  | OPC A |  | 12-053 |  |  |  |  |  |  |  |  |  |  |  |  |  |  |  |
| 142231355a | Fabricate Patch Panels for LV&HV FY13 | 90d | 2013-08-30 A | 2013-08-30 A | 142231355 | 100% |  | 2013-11-06 | 2014-03-25 |  |  |  | ELEC TECH [16.09 h]; SKLLD TRADE [8.04 h] | 1,042.45 | 1,010.28 |  |  |  |  | 1010.2794 | 1010.2794 | IN | ELOUADRHIRI L | 1 | 1 | H | LATIFA E | 09-030 | 11-026 | 12-007 |  |  |  | 12-053 |  |  |  |  |  |  |  |  |  |  |  |  |  |  |  |
| 142231360 | Fabricate Splitter Parts FY12 | 24d | 2013-08-30 A | 2013-08-30 A | 142231350, 142231345 | 100% |  | 2013-10-03 | 2013-11-05 |  |  |  | ELEC TECH [44.85 h]; SCIENTIST [44.85 h]; SKLLD TRADE [11.21 h] | 5,878.62 | 5,697.21 |  |  |  |  | 5521.0635 | 5521.0635 | IN | ELOUADRHIRI L | 1 | 1 | H | LATIFA E | 09-030 | 11-026 | 12-007 |  | OPC A |  | 12-053 |  |  |  |  |  |  |  |  |  |  |  |  |  |  |  |
| 142231360a | Fabricate Splitter Parts FY13 | 38d | 2013-08-30 A | 2013-08-30 A | 142231360 | 100% |  | 2013-11-06 | 2014-01-08 |  |  |  | ELEC TECH [19.15 h]; SCIENTIST [19.15 h]; SKLLD TRADE [4.79 h] | 2,510.18 | 2,432.71 |  |  |  |  | 2432.7108 | 2432.7108 | IN | ELOUADRHIRI L | 1 | 1 | H | LATIFA E | 09-030 | 11-026 | 12-007 |  |  |  | 12-053 |  |  |  |  |  |  |  |  |  |  |  |  |  |  |  |
| 142231365 | Assembling of the CTOF patch panels | 53d | 2013-08-30 A | 2013-08-30 A | 142231355a | 100% |  | 2014-03-26 | 2014-06-09 |  |  |  | SCIENTIST [8 h]; MECH TECH [8 h] | 980 | 949.76 |  |  |  |  | 949.76 | 949.76 | IN | ELOUADRHIRI L | 1 | 1 | H | LATIFA E | 09-030 | 11-026 | 12-007 |  | OPC A |  |  |  |  |  |  |  |  |  |  |  |  |  |  |  |  |  |
| 142231370 | Assembling of the CTOF splitters | 105d | 2013-08-30 A | 2013-08-30 A | 142231360a | 100% |  | 2014-01-09 | 2014-06-09 |  |  |  | SCIENTIST [10.91 h]; MECH TECH [109.09 h] | 5,982.33 | 5,797.75 |  |  |  |  | 5797.745457 | 5797.745457 | IN | ELOUADRHIRI L | 1 | 1 | H | LATIFA E | 09-030 | 11-026 | 12-007 |  | OPC A |  |  |  |  |  |  |  |  |  |  |  |  |  |  |  |  |  |
| 142231390 | Install PMT and check the orientation | 116d | 2013-08-30 A | 2013-08-30 A | 142231380a, 142231245a | 100% |  | 2013-10-07 | 2014-03-31 |  |  |  | SCIENTIST [104 h]; MECH TECH [104 h] | 12,740 | 12,346.88 |  |  |  |  | 12346.88 | 12346.88 | IN | ELOUADRHIRI L | 1 | 1 | U | LATIFA E | 09-030 | 11-026 | 12-007 |  |  | 12-054 |  |  |  |  |  |  |  |  |  |  |  |  |  |  |  |  |
| 142231395 | Install shield disks onto the Light guides | 108d | 2013-08-30 A | 2013-08-30 A | 142231300b, 142231310, 142231305b, 142231310b, 142231300a, 142231310a, 142231245a, 142231305a | 100% |  | 2013-10-09 | 2014-03-21 |  |  |  | SCIENTIST [104 h]; MECH TECH [208 h] | 17,661.28 | 17,116.32 |  |  |  |  | 17116.32 | 17116.32 | IN | ELOUADRHIRI L | 1 | 1 | U | LATIFA E | 09-030 | 11-026 | 12-007 |  |  | 12-054 |  |  |  |  |  |  |  |  |  |  |  |  |  |  |  |  |
| 142231400 | Install compensation coils and check polarity | 110d | 2013-08-30 A | 2013-08-30 A | 142231245a, 142231295a | 100% |  | 2013-10-09 | 2014-03-25 |  |  |  | SCIENTIST [52 h]; MECH TECH [52 h] | 6,370 | 6,173.44 |  |  |  |  | 6173.44 | 6173.44 | IN | ELOUADRHIRI L | 1 | 1 | U | LATIFA E | 09-030 | 11-026 | 12-007 |  |  | 12-054 |  |  |  |  |  |  |  |  |  |  |  |  |  |  |  |  |
| 142231405 | Install Middle. Mag. Shields onto PMT | 110d | 2013-08-30 A | 2013-08-30 A | 142231245a, 142231300a, 142231310, 142231305b, 142231310b, 142231310a, 142231300b, 142231305a | 100% |  | 2013-10-09 | 2014-03-25 |  |  |  | SCIENTIST [104 h]; MECH TECH [104 h] | 12,740 | 12,346.88 |  |  |  |  | 12346.88 | 12346.88 | IN | ELOUADRHIRI L | 1 | 1 | U | LATIFA E | 09-030 | 11-026 | 12-007 |  |  | 12-054 |  |  |  |  |  |  |  |  |  |  |  |  |  |  |  |  |
| 142231410 | CTOF in Storage Rack cabling | 29d | 2013-08-30 A | 2013-08-30 A | 142231310b FS+10d, 142231300a FS+10d, 142231300b FS+10d, 142231305a FS+10d, 142231340a, 142231335, 142231305b FS+10d, 142231310 FS+10d, 142231245a, 142231380a, 142231310a FS+10d | 100% |  | 2014-04-23 | 2014-06-03 |  |  |  | SCIENTIST [20 h]; MECH TECH [40 h] | 3,396.4 | 3,291.6 |  |  |  |  | 3291.6 | 3291.6 | IN | ELOUADRHIRI L | 1 | 1 | H | LATIFA E | 09-030 | 11-026 | 12-007 |  |  | 12-054 |  |  |  |  |  |  |  |  |  |  |  |  |  |  |  |  |
| 142231420 | Standalone CTOF testing/optimizing | 108d | 2013-08-30 A | 2013-08-30 A | 142231250 FS+29d, 142231410, 142231365, 142231395, 142231415a, 142231405, 142231255 FS+29d, 142231115a, 142231400, 142231245a FS+29d, 142231390, 142231370 | 100% |  | 2013-10-14 | 2014-03-26 |  |  |  | SCIENTIST [13.89 h]; CONTRB UNIV LBR [162.96 h] | 1,044.16 | 1,011.93 |  |  |  |  | 10929 | 1011.933815 |  | ELOUADRHIRI L | 1 | 1 | U | LATIFA E |  | 11-026 | 12-007 |  |  | 12-054 |  |  |  |  |  |  |  |  |  |  |  |  |  |  |  |  |
| 142231475 | Re-Baseline Actuals Adjustment | 1d | 2013-08-30 A | 2013-08-30 A |  | 100% |  | 2013-09-03 | 2013-09-03 |  |  |  | PROCUREMENT>$50K 69 NO ESCALATION | -261,730.13 |  |  |  |  | 100 |  |  |  |  |  |  |  |  |  |  |  |  |  |  |  | ADJ |  |  |  |  |  |  |  |  |  |  |  |  |  |  |
| 242231013E | CTOF-FY13 Travel | 20d | 2013-09-03 A | 2013-09-30 A | 9-130M FS+228d | 100% |  | 2013-10-01 | 2013-10-28 |  |  | 8/5 M-F w/JLAB Holidays ReBaseline | TRAVEL | 485.41 |  |  |  |  |  |  | 0 |  | ELOUADRHIRI L | 1 | 1 | E | LATIFA E |  |  | 12-007 |  |  |  |  |  | 100 | 100 | 242231013E | 485.41 | 07-024 | 13-002F | PE | 13-015 | PR |  |  |  |  |  |
| 242231120 | Refurbish Laser Calibration System FY 13 Obligated Procurement | 20d | 2013-09-03 A | 2013-09-23 A | 9-130M FS+228d | 100% |  | 2013-10-01 | 2013-10-28 |  |  | 8/5 M-F w/JLAB Holidays ReBaseline | PROCUREMENT<$50K 60 | 70.38 |  | 0 | 70.38 | 7038 | 100 |  | 0 |  | ELOUADRHIRI L | 1 | 1 | U | LATIFA E |  | 11-026 | 12-007 |  |  |  | 12-053 |  |  |  | 242231115 | 70.38 |  | 13-002F | PE | 13-015 | PR | PE | PE | OB |  |  |
| 242231125 | Purchase UV Glue, Tooling and Materials | 203d | 2013-10-01 A | 2014-07-31 | 9-140M FS+2d | 5% | 182d | 2013-11-01 | 2014-08-29 | 174d | 56d | 8/5 M-F w/JLAB Holidays ReBaseline | SUPPLIES & MATERIALS | 1,346.63 |  |  |  |  |  |  | 67.3315 |  | ELOUADRHIRI L | 1 | 1 | D | LATIFA E |  | 11-026 | 12-007 |  |  | 12-054F |  |  |  |  | 242231125 |  |  | 13-002F | PE | 13-015 | PR | PE |  |  | 14-001 |  |
| 242231140 | Final Drawings of Tooling for wrapping | 57d | 2013-10-01 A | 2013-12-20 | 9-140M | 50% | 34d | 2013-11-01 | 2014-02-04 | 121d | 3d | 8/5 M-F w/JLAB Holidays ReBaseline | MECH DES [40 h] | 2,052 | 828 |  |  |  |  |  | 1026 |  | ELOUADRHIRI L | 1 | 1 | H | LATIFA E |  | 11-026 | 12-007 |  |  | 12-054F |  |  |  |  | 242231140 |  |  | 13-002F |  | 13-015 | PR |  | PE |  | 14-001 |  |
| 242231215 | Polishing/finishing LG | 58d | 2013-10-01 A | 2014-01-02 | 242231200 FS-140d, 242231205 FS-140d, 9-140M | 15% | 35d | 2013-11-01 | 2014-02-05 | 138d | 20d | 8/5 M-F w/JLAB Holidays ReBaseline | SCIENTIST [32 h]; MECH TECH [88 h]; MSHOP; VISTNG USERS [160 h] | 11,020.05 | 3,911.71 |  |  |  |  |  | 1653.0075 | IN | ELOUADRHIRI L | 1 | 1 | U | LATIFA E | 09-030 | 11-026 | 12-007 |  |  | 12-054F |  |  |  |  | 242231215 |  |  | 13-002F | PE | 13-015 | PR |  | PE |  | 14-001 |  |
| 242231220 | Wrapping and Transmittance test of LG | 70d | 2013-10-04 A | 2014-01-24 | 242231215 FS-55d | 5% | 50d | 2013-11-06 | 2014-02-26 | 133d | 0d | 8/5 M-F w/JLAB Holidays ReBaseline | MECH TECH [240 h]; VISTNG USERS [240 h] | 16,298.4 | 4,656.69 |  |  |  |  |  | 814.92 |  | ELOUADRHIRI L | 1 | 1 | U | LATIFA E |  | 11-026 | 12-007 |  |  | 12-054F |  |  |  |  | 242231220 |  |  | 13-002F |  | 13-015 | PR |  | PE |  | 14-001 |  |
| 242231115 | Refurbish Laser Calibration System | 225d | 2013-11-01 | 2014-10-01 | 9-140M FS+2d |  |  |  |  | 251d | 206d | 8/5 M-F w/JLAB Holidays ReBaseline | SCIENTIST [102 h]; MECH DES [102 h]; MECH TECH [102 h]; SUPPLIES & MATERIALS | 24,862.93 |  |  |  |  |  |  | 0 |  | ELOUADRHIRI L | 1 | 1 | U | LATIFA E |  | 11-026 | 12-007 |  |  |  | 12-053 |  |  |  | 242231115 |  |  | 13-002F | PE | 13-015 | PR | PE | PE |  | 14-001 |  |
| 242231145 | Fabricate Tooling for Wrapping | 55d | 2013-11-01 | 2014-01-31 | 242231140 FS-37d |  |  |  |  | 118d | 0d | 8/5 M-F w/JLAB Holidays ReBaseline | MECH TECH [40 h]; MSHOP | 4,457.07 |  |  |  |  |  |  | 0 |  | ELOUADRHIRI L | 1 | 1 | S | LATIFA E |  | 11-026 | 12-007 |  |  | 12-054F |  |  |  |  | 242231145 |  |  | 13-002F | PE | 13-015 | PR |  | PE |  | 14-001 | ST |
| 242231200 | Purchase buffing tools and materials | 77d | 2013-11-01 | 2014-03-04 | 9-140M FS+2d |  |  |  |  | 201d | 63d | 8/5 M-F w/JLAB Holidays ReBaseline | SUPPLIES & MATERIALS; SCIENTIST [9.96 h] | 5,324.23 |  |  |  |  |  |  | 0 | IN | ELOUADRHIRI L | 1 | 1 | D | LATIFA E | 09-030 | 11-026 | 12-007 |  |  | 12-054F |  |  |  |  | 242231200 |  |  | 13-002F | PE | 13-015 | PR | PE | PE |  | 14-001 |  |
| 242231205 | Purchase 900 shts, 12 sqin, VM2002, for wrapping | 77d | 2013-11-01 | 2014-03-04 | 9-140M FS+2d |  |  |  |  | 162d | 44d | 8/5 M-F w/JLAB Holidays ReBaseline | PROCUREMENT<$50K 60 | 2,568.92 |  | 2568.92 | 0 | 0 | 100 |  | 0 | IN | ELOUADRHIRI L | 1 | 1 | D | LATIFA E | 09-030 | 11-026 | 12-007 |  |  | 12-054F |  |  |  |  | 242231205 |  |  | 13-002F |  | 13-015 | PR | CP |  |  | 14-001 |  |
| 242231260 | Final Drawings of CTOF Support and Solenoid Harness | 156d | 2013-11-01 | 2014-06-24 | 9-140M FS+2d |  |  |  |  | 151d | 0d | 8/5 M-F w/JLAB Holidays ReBaseline | MECH DES [160 h] | 8,208 |  |  |  |  |  |  | 0 |  | ELOUADRHIRI L | 1 | 1 | S | LATIFA E |  | 11-026 | 12-007 |  |  |  |  |  |  |  | 242231260 |  |  | 13-002F |  | 13-015 | PR |  | PE |  | 14-001 | ST |
| 242231460 | Purchase stabilized dividers for H2431 PMTs | 77d | 2013-11-04 | 2014-03-05 | 9-140M FS+24d |  |  |  |  | 242.5d | 0d | 8/5 M-F w/JLAB Holidays ReBaseline | PROCUREMENT<$50K 60 | 4,323.15 |  | 4323.15 | 0 | 0 | 100 |  | 0 |  | ELOUADRHIRI L | 1 | 1 | U | LATIFA E |  | 11-026 | 12-007 |  |  |  | 12-053 |  |  |  | 242231460 |  |  | 13-002F |  | 13-015 | PR | PE |  |  | 14-001 |  |
| 242231285 | Final Drawings of Magnetic Shield Components | 58d | 2013-11-21 | 2014-02-25 | 9-140M FS+37d |  |  |  |  | 192d | 0d | 8/5 M-F w/JLAB Holidays ReBaseline | MECH DES [200 h] | 10,260 |  |  |  |  |  |  | 0 | IN | ELOUADRHIRI L | 1 | 1 | S | LATIFA E | 09-030 | 11-026 | 12-007 |  |  |  |  |  |  |  | 242231285 |  |  | 13-002F |  | 13-015 | PR |  | PE |  | 14-001 | ST |
| 242231270 | Final drawings for counter installation arm - cart and transport rack | 233d | 2013-11-26 | 2014-11-05 | 242231260 FS-139d |  |  |  |  | 151d | 0d | 8/5 M-F w/JLAB Holidays ReBaseline | MECH DES [480 h] | 24,624 |  |  |  |  |  |  | 0 |  | ELOUADRHIRI L | 1 | 1 | S | LATIFA E |  | 11-026 | 12-007 |  |  | 12-054F |  |  |  |  | 242231270 |  |  | 13-002F |  | 13-015 | PR |  | PE |  | 14-001 | ST |
| 242231280 | Final Drawings of Magnetic Shield Compensating Coil | 49d | 2013-12-06 | 2014-02-25 | 9-140M FS+46d |  |  |  |  | 206d | 0d | 8/5 M-F w/JLAB Holidays ReBaseline | MECH DES [120 h] | 6,156 |  |  |  |  |  |  | 0 | IN | ELOUADRHIRI L | 1 | 1 | H | LATIFA E | 09-030 | 11-026 | 12-007 |  |  |  |  |  |  |  | 242231280 |  |  | 13-002F |  | 13-015 | PR |  | PE |  | 14-001 |  |
| 242231287 | Magnetic Shield Engineering Analysis | 21d | 2013-12-20 | 2014-01-30 | 242231285 FS-39d |  |  |  |  | 210d | 18d | 8/5 M-F w/JLAB Holidays ReBaseline | MECH ENG [120 h] | 8,960.4 |  |  |  |  |  |  | 0 | IN | ELOUADRHIRI L | 1 | 1 | H | LATIFA E | 09-030 | 11-026 | 12-007 |  |  |  |  |  |  |  | 242231287 |  |  | 13-002F |  | 13-015 | PR |  | PE |  | 14-001 |  |
| 242231245 | Two-side glue Counters in Support Arm | 133d | 2014-01-27 | 2014-08-01 | 242231220, 242231215 FS-35d |  |  |  |  | 133d | 0d | 8/5 M-F w/JLAB Holidays ReBaseline | VISTNG USERS [480 h]; MECH TECH [240 h] | 21,240 |  |  |  |  |  |  | 0 |  | ELOUADRHIRI L | 1 | 1 | U | LATIFA E |  | 11-026 | 12-007 |  |  | 12-054F | 12-053 |  |  |  | 242231245 |  |  | 13-002F |  | 13-015 | PR |  | PE |  | 14-001 |  |
| 242231250 | Counter-in-rack storage and wrapping | 109d | 2014-02-03 | 2014-07-07 | 242231215, 242231125 FS-183d, 242231145, 242231205 FS-66d, 242231220 FS-30d |  |  |  |  | 118d | 0d | 8/5 M-F w/JLAB Holidays ReBaseline | SCIENTIST [80 h]; MECH TECH [200 h]; VISTNG USERS [400 h] | 23,714.4 |  |  |  |  |  |  | 0 |  | ELOUADRHIRI L | 1 | 1 | U | LATIFA E |  | 11-026 | 12-007 |  |  |  |  |  |  |  | 242231250 |  |  | 13-002F |  | 13-015 | PR |  | PE |  | 14-001 |  |
| 242231262 | CTOF Support and Solenoid Harness Engineer analysis | 117d | 2014-02-11 | 2014-07-25 | 242231260 FS-95d |  |  |  |  | 167d | 46d | 8/5 M-F w/JLAB Holidays ReBaseline | MECH ENG [120 h] | 8,960.4 |  |  |  |  |  |  | 0 |  | ELOUADRHIRI L | 1 | 1 | S | LATIFA E |  | 11-026 | 12-007 |  |  |  |  |  |  |  | 242231262 |  |  | 13-002F |  | 13-015 | PR |  | PE |  | 14-001 | ST |
| 242231465 | Soldering the stabilized dividers for H2431 PMTs | 80.5d | 2014-02-21 | 2014-06-16 | 242231460 FS-9d |  |  |  |  | 242.5d | 0d | 8/5 M-F w/JLAB Holidays ReBaseline | ELEC TECH [100 h]; VISTNG USERS [100 h] | 6,758 |  |  |  |  |  |  | 0 |  | ELOUADRHIRI L | 1 | 1 | S | LATIFA E |  | 11-026 | 12-007 |  |  |  | 12-053 |  |  |  | 242231465 |  |  | 13-002F |  | 13-015 | PR |  | PE |  | 14-001 | ST |
| 242231430 | Purchase incidentals/tools/material | 67d | 2014-02-24 | 2014-05-28 | 9-140M FS+94d |  |  |  |  | 338d | 293d | 8/5 M-F w/JLAB Holidays ReBaseline | SUPPLIES & MATERIALS | 19,093.25 |  |  |  |  |  |  | 0 |  | ELOUADRHIRI L | 1 | 1 | D | LATIFA E |  | 11-026 | 12-007 |  |  |  | 12-053 |  |  |  | 242231430 |  |  | 13-002F | PE | 13-015 | PR |  |  |  | 14-001 |  |
| 242231435 | Purchase/Fabricate/Ship Middle Mag. Disks-2 Procurement | 67d | 2014-02-24 | 2014-05-28 | 9-140M FS+94d |  |  |  |  | 213d | 80d | 8/5 M-F w/JLAB Holidays ReBaseline | PROCUREMENT<$50K 60 | 10,649.21 |  | 10649.21 | 0 | 0 | 100 |  | 0 |  | ELOUADRHIRI L | 1 | 1 | U | LATIFA E |  | 11-026 | 12-007 |  |  |  | 12-053 |  |  |  | 242231435 |  |  | 13-002F |  | 13-015 | PR | PE |  |  | 14-001 |  |
| 242231440 | Purchase/Fabricate/Ship Extern. Mag. Disks-1 Procurement | 67d | 2014-02-24 | 2014-05-28 | 9-140M FS+94d |  |  |  |  | 213d | 80d | 8/5 M-F w/JLAB Holidays ReBaseline | PROCUREMENT<$50K 60 | 10,649.21 |  | 10649.21 | 0 | 0 | 100 |  | 0 |  | ELOUADRHIRI L | 1 | 1 | U | LATIFA E |  | 11-026 | 12-007 |  |  |  | 12-053 |  |  |  | 242231440 |  |  | 13-002F |  | 13-015 | PR | PE |  |  | 14-001 |  |
| 242231445 | Purchase/Fabricate/Ship Extern. Mag. Disks-2 Procurement | 67d | 2014-02-24 | 2014-05-28 | 9-140M FS+94d |  |  |  |  | 213d | 80d | 8/5 M-F w/JLAB Holidays ReBaseline | PROCUREMENT<$50K 60 | 10,649.21 |  | 10649.21 | 0 | 0 | 100 |  | 0 |  | ELOUADRHIRI L | 1 | 1 | U | LATIFA E |  | 11-026 | 12-007 |  |  |  | 12-053 |  |  |  | 242231445 |  |  | 13-002F |  | 13-015 | PR | PE |  |  | 14-001 |  |
| 242231290 | Purchase Coil components and materials | 25d | 2014-02-26 | 2014-04-01 | 242231285, 242231280 |  |  |  |  | 206d | 0d | 8/5 M-F w/JLAB Holidays ReBaseline | SUPPLIES & MATERIALS | 11,553.15 |  |  |  |  |  |  | 0 | IN | ELOUADRHIRI L | 1 | 1 | D | LATIFA E | 09-030 | 11-026 | 12-007 |  |  |  |  |  |  |  | 242231290 |  |  | 13-002F | PE | 13-015 | PR |  |  |  | 14-001 |  |
| 242231305 | Purchase/Fabricate/Ship Inner Mag. Cylinder Procurement | 96d | 2014-03-10 | 2014-07-23 | 242231287 FS+8d, 242231285 FS+8d |  |  |  |  | 192d | 73d | 8/5 M-F w/JLAB Holidays ReBaseline | PROCUREMENT<$50K 60 | 11,392.18 |  | 11392.18 | 0 | 0 | 100 |  | 0 | IN | ELOUADRHIRI L | 1 | 1 | D | LATIFA E | 09-030 | 11-026 | 12-007 |  |  |  | 12-053 |  |  |  | 242231305 |  |  | 13-002F |  | 13-015 | PR | PE |  |  | 14-001 |  |
| 242231295 | Fabricate Compensating Coil Machine Shop | 43d | 2014-03-27 | 2014-05-27 | 242231280, 242231290 FS-4d |  |  |  |  | 268d | 135d | 8/5 M-F w/JLAB Holidays ReBaseline | MSHOP | 8,497.7 |  |  |  |  |  |  | 0 | IN | ELOUADRHIRI L | 1 | 1 | D | LATIFA E | 09-030 | 11-026 | 12-007 |  |  |  | 12-053 |  |  |  | 242231295 |  |  | 13-002F | EJ | 13-015 | PR |  |  |  | 14-001 |  |
| 242231300 | Fabricate Compensating Coil Procurement | 43d | 2014-03-27 | 2014-05-27 | 242231280 FS-110d, 242231290 FS-4d |  |  |  |  | 206d | 73d | 8/5 M-F w/JLAB Holidays ReBaseline | PROCUREMENT<$50K 60 | 21,137.44 |  | 21137.44 | 0 | 0 | 100 |  | 0 | IN | ELOUADRHIRI L | 1 | 1 | D | LATIFA E | 09-030 | 11-026 | 12-007 |  |  |  | 12-053 |  |  |  | 242231300 |  |  | 13-002F |  | 13-015 | PR | PE |  |  | 14-001 |  |
| 242231390 | Install PMT and check the orientation | 70d | 2014-04-03 | 2014-07-14 | 242231465 FS-51d |  |  |  |  | 242.5d | 197.5d | 8/5 M-F w/JLAB Holidays ReBaseline | SCIENTIST [40 h]; MECH TECH [80 h] | 6,792.8 |  |  |  |  |  |  | 0 | IN | ELOUADRHIRI L | 1 | 1 | U | LATIFA E | 09-030 | 11-026 | 12-007 |  |  | 12-054 |  |  |  |  | 242231390 |  |  | 13-002F |  | 13-015 | PR |  | PE |  | 14-001 |  |
| 242231450 | Purchase/Fabricate/Ship Inner Mag. Cylinder #1 | 35d | 2014-04-09 | 2014-05-28 | 9-140M FS+126d |  |  |  |  | 213d | 80d | 8/5 M-F w/JLAB Holidays ReBaseline | PROCUREMENT<$50K 60 | 11,392.18 |  | 11392.18 | 0 | 0 | 100 |  | 0 |  | ELOUADRHIRI L | 1 | 1 | U | LATIFA E |  | 11-026 | 12-007 |  |  |  | 12-053 |  |  |  | 242231450 |  |  | 13-002F |  | 13-015 | PR | PE |  |  | 14-001 |  |
| 242231455 | Purchase/Fabricate/Ship Inner Non-mag. Cylinder #2 | 35d | 2014-04-09 | 2014-05-28 | 9-140M FS+126d |  |  |  |  | 213d | 80d | 8/5 M-F w/JLAB Holidays ReBaseline | PROCUREMENT<$50K 60 | 11,392.18 |  | 11392.18 | 0 | 0 | 100 |  | 0 |  | ELOUADRHIRI L | 1 | 1 | U | LATIFA E |  | 11-026 | 12-007 |  |  |  | 12-053 |  |  |  | 242231455 |  |  | 13-002F |  | 13-015 | PR | PE |  |  | 14-001 |  |
| 242231272 | Counter installation arm - cart and transport rack Engineering Analysis | 74d | 2014-04-18 | 2014-08-01 | 9-140M FS+110d, 242231270 FS-141d |  |  |  |  | 151d | 0d | 8/5 M-F w/JLAB Holidays ReBaseline | MECH ENG [160 h] | 11,947.2 |  |  |  |  |  |  | 0 |  | ELOUADRHIRI L | 1 | 1 | S | LATIFA E |  | 11-026 | 12-007 |  |  | 12-054F |  |  |  |  | 242231272 |  |  | 13-002F |  | 13-015 | PR |  | PE |  | 14-001 | ST |
| 242231255 | Transmittance test of assembled Counters in Rack | 120d | 2014-06-09 | 2014-11-25 | 242231125 FS-183d, 242231215, 242231250 FS-20d, 242231220 |  |  |  |  | 118d | 73d | 8/5 M-F w/JLAB Holidays ReBaseline | MECH TECH [80 h]; VISTNG USERS [120 h]; SCIENTIST [80 h] | 12,270.8 |  |  |  |  |  |  | 0 |  | ELOUADRHIRI L | 1 | 1 | S | LATIFA E |  | 11-026 | 12-007 |  |  |  |  |  |  |  | 242231255 |  |  | 13-002F |  | 13-015 | PR |  | PE |  | 14-001 | ST |
| 242231395 | Install shield disks onto the Light guides | 70d | 2014-09-09 | 2014-12-17 | 242231285 FS-110d, 242231245 FS+25d, 242231445 FS-9d, 242231440 FS-9d, 242231435 FS-9d, 242231305 FS-41d |  |  |  |  | 133d | 88d | 8/5 M-F w/JLAB Holidays ReBaseline | SCIENTIST [80 h]; MECH TECH [104 h] | 10,935.68 |  |  |  |  |  |  | 0 | IN | ELOUADRHIRI L | 1 | 1 | U | LATIFA E | 09-030 | 11-026 | 12-007 |  |  | 12-054 |  |  |  |  | 242231395 |  |  | 13-002F |  | 13-015 | PR |  | PE |  | 14-001 |  |
| 242231400 | Install compensation coils and check polarity | 70d | 2014-09-09 | 2014-12-17 | 242231245 FS+25d, 242231455 FS-9d, 242231295 FS-63d, 242231460 FS-9d, 242231300 FS-1d, 242231450 FS-9d |  |  |  |  | 133d | 88d | 8/5 M-F w/JLAB Holidays ReBaseline | SCIENTIST [96 h]; MECH TECH [96 h] | 11,760 |  |  |  |  |  |  | 0 | IN | ELOUADRHIRI L | 1 | 1 | U | LATIFA E | 09-030 | 11-026 | 12-007 |  |  | 12-054 |  |  |  |  | 242231400 |  |  | 13-002F |  | 13-015 | PR |  | PE |  | 14-001 |  |
| 242231405 | Install Middle. Mag. Shields onto PMT | 70d | 2014-09-09 | 2014-12-17 | 242231285 FS-110d, 242231245 FS+25d, 242231305 FS-41d |  |  |  |  | 133d | 88d | 8/5 M-F w/JLAB Holidays ReBaseline | SCIENTIST [192 h]; MECH TECH [192 h] | 23,520 |  |  |  |  |  |  | 0 | IN | ELOUADRHIRI L | 1 | 1 | U | LATIFA E | 09-030 | 11-026 | 12-007 |  |  | 12-054 |  |  |  |  | 242231405 |  |  | 13-002F |  | 13-015 | PR |  | PE |  | 14-001 |  |
| 242231275 | CTOF procure installation tooling and transport rack | 111d | 2014-09-16 | 2015-03-04 | 242231272 FS+30d, 242231270 FS-38d |  |  |  |  | 151d | 106d | 8/5 M-F w/JLAB Holidays ReBaseline | PROCUREMENT<$50K 60 NO ESCALATION FY15 | 11,352.96 |  | 11352.96 | 0 | 0 | 100 |  | 0 |  | ELOUADRHIRI L | 1 | 1 | D | LATIFA E |  | 11-026 | 12-007 |  |  | 12-054 | 12-053 |  |  |  | 242231275 |  |  | 13-002F |  | 13-015 | PR | PE |  |  | 14-001 |  |
| 242231325 | Assemble the Setup for Magnetic Shields Tests | 63d | 2014-09-17 | 2014-12-16 | 242231320 FS-68d |  |  |  |  | 173d | 0d | 8/5 M-F w/JLAB Holidays ReBaseline | MECH ENG [80 h]; MECH TECH [120 h]; VISTNG USERS [120 h]; SCIENTIST [80 h] | 20,137.2 |  |  |  |  |  |  | 0 | IN | ELOUADRHIRI L | 1 | 1 | S | LATIFA E | 09-030 | 11-026 | 12-007 | 12-027 |  | 12-054F |  |  |  |  | 242231325 |  |  | 13-002F |  | 13-015 | PR |  | PE |  | 14-001 | ST |
| 242231320 | Purchase DCPS 6030A 200V/17A Ext.Magn. Shield | 67d | 2014-09-18 | 2014-12-23 | 9-140M FS+239d |  |  |  |  | 173d | 0d | 8/5 M-F w/JLAB Holidays ReBaseline | PROCUREMENT<$50K 60 NO ESCALATION FY15 | 32,362.45 |  | 32362.45 | 0 | 0 | 100 |  | 0 | IN | ELOUADRHIRI L | 1 | 1 | U | LATIFA E | 09-030 | 11-026 | 12-007 | 12-027 |  | 12-054F |  |  |  |  | 242231320 |  |  | 13-002F |  | 13-015 | PR | PE |  |  | 14-001 |  |
| 242231265 | CTOF procure support and solenoid harness and interface rings | 110d | 2014-10-01 | 2015-03-18 | 9-155M, 242231260, 242231262 |  |  |  |  | 121d | 76d | 8/5 M-F w/JLAB Holidays ReBaseline | PROCUREMENT<$50K 60 | 45,478.93 |  | 45478.93 | 0 | 0 | 100 |  | 0 |  | ELOUADRHIRI L | 1 | 1 | D | LATIFA E |  | 11-026 | 12-007 |  |  |  | 12-053 |  |  |  | 242231265 |  |  | 13-002F |  | 13-015 | PR | PE |  |  | 14-001 |  |
| 242231335 | Purchase Cables and Connectors | 41d | 2014-10-06 | 2014-12-03 | 9-155M FS+3d |  |  |  |  | 45d | 0d | 8/5 M-F w/JLAB Holidays ReBaseline | SCIENTIST [24 h]; PROCUREMENT<$50K 60 | 47,835.32 |  | 46031 | 0 | 0 | 100 |  | 0 | IN | ELOUADRHIRI L | 1 | 1 | D | LATIFA E | 09-030 | 11-026 | 12-007 |  |  |  |  |  |  |  | 242231335 |  |  | 13-002F |  | 13-015 | PR | CP | PE |  | 14-001 |  |
| 242231345 | Final Drawings of Patch Panels for LV & HV;200 ch | 9d | 2014-10-06 | 2014-10-16 | 9-155M FS+3d |  |  |  |  | 81d | 0d | 8/5 M-F w/JLAB Holidays ReBaseline | MECH DES [80 h] | 4,104 |  |  |  |  |  |  | 0 | IN | ELOUADRHIRI L | 1 | 1 | H | LATIFA E | 09-030 | 11-026 | 12-007 |  |  |  |  |  |  |  | 242231345 |  |  | 13-002F |  | 13-015 | PR |  | PE |  | 14-001 |  |
| 242231350 | Final Drawings of Splitter to TDC and ADC; 100 ch | 42d | 2014-10-17 | 2014-12-17 | 242231345 |  |  |  |  | 81d | 0d | 8/5 M-F w/JLAB Holidays ReBaseline | MECH DES [80 h] | 4,104 |  |  |  |  |  |  | 0 | IN | ELOUADRHIRI L | 1 | 1 | H | LATIFA E | 09-030 | 11-026 | 12-007 |  |  |  |  |  |  |  | 242231350 |  |  | 13-002F |  | 13-015 | PR |  | PE |  | 14-001 |  |
| 242231355 | Fabricate Patch Panels for LV&HV | 84d | 2014-10-17 | 2015-02-26 | 242231345 |  |  |  |  | 81d | 0d | 8/5 M-F w/JLAB Holidays ReBaseline | MECH TECH [120 h]; SCIENTIST [40 h]; VISTNG USERS [40 h]; ELEC TECH [120 h] | 15,148 |  |  |  |  |  |  | 0 | IN | ELOUADRHIRI L | 1 | 1 | U | LATIFA E | 09-030 | 11-026 | 12-007 |  |  |  | 12-053 |  |  |  | 242231355 |  |  | 13-002F |  | 13-015 | PR |  | PE |  | 14-001 |  |
| 242231340 | Fabricate Cables LV&HV | 82d | 2014-11-07 | 2015-03-17 | 242231335 FS-17d |  |  |  |  | 45d | 0d | 8/5 M-F w/JLAB Holidays ReBaseline | MECH TECH [200 h]; SCIENTIST [40 h]; VISTNG USERS [40 h] | 13,294.8 |  |  |  |  |  |  | 0 | IN | ELOUADRHIRI L | 1 | 1 | U | LATIFA E | 09-030 | 11-026 | 12-007 |  |  |  | 12-053 |  |  |  | 242231340 |  |  | 13-002F |  | 13-015 | PR |  | PE |  | 14-001 |  |
| 242231360 | Fabricate Splitter Parts | 33d | 2014-12-17 | 2015-02-12 | 242231350 FS-1d, 242231345 FS-1d |  |  |  |  | 81d | 0d | 8/5 M-F w/JLAB Holidays ReBaseline | ELEC TECH [40 h]; SCIENTIST [40 h]; MECH TECH [80 h] | 8,672.4 |  |  |  |  |  |  | 0 | IN | ELOUADRHIRI L | 1 | 1 | H | LATIFA E | 09-030 | 11-026 | 12-007 |  |  |  | 12-053 |  |  |  | 242231360 |  |  | 13-002F |  | 13-015 | PR |  | PE |  | 14-001 |  |

Notes:
- 242231145: Steps: Complete design for tooling; Complete testing phase; Complete fabrication
- 242231260: Steps: Complete drawings of CTOF support; Complete drawings of CTOF solenoid harness
- 242231285: Steps: Complete drawings for compensation coil and bayonet connector; Complete drawings for end-cap cones; Complete drawings for inner shield
- 242231270: Steps: Complete drawing package for cart system; Complete drawing package for transport rack
- 242231262: Steps: Deformation calculation; Stress analysis
- 242231465: Steps: Purchase 130 PCB boards with components; Dismount PMT shields; Solder PCB board to the PMT base; Mount PMT shield
- 242231272: Steps: Fabrication of installation arm cart; Fabrication of CTOF counter transportation rack
- 242231255: Steps: Test of rack 1; Test of rack 2; Test of rack 3; Test of rack 4; Test of rack 5; Test of rack 6
- 242231325: Steps: Install and power SC solenoid; Install support for the magnetic shield; Install magnetic sensors

| ID | WBS | Activity | Type | Duration | Start | Finish | Predecessors | Complete | Planned start | Planned finish | Total float | Free float | Calendar | Resources | Cost | Actual cost | Original Activity ID Rebaseline | MONTHLY EV COST | PHAS - Project Phase | RESP - Responsibility | STRT%COMP for CM EVM | FNSH%COMP for CM EVM | EVMS Reporting Codes | CAM RESPONSIBLE | CR 09-030 Repair | CR 11-026 | CR 12-007 | CR 12-027 | CR 12-054 | CR 13-002 | BOE Labor | CR 13-015 | Post Rebaseline | CR 14-001 | CR 12-053 | Activities with Steps | CR 10-017 | CR 11-021 | CR 11-035 | Calculated Remaining Total Cost | Advance Purchase Plan > 500K | CR 08-045 | LOE Divider | LOE Multiplier | CR 11-001 | CR 11-032 | Remaining Material Cost Based on % Compl | Claimed Material Cost Based on % Complet | Initial Claimed Material Calc | Claimed Material Divider | LOE % Pre Calc | LOE % | CR 11-009 | CR 11-038 | CR 12-001 | CR 11-056 | Phil Dev | MARCH!!! |
| --- | --- | --- | --- | --- | --- | --- | --- | --- | --- | --- | --- | --- | --- | --- | --- | --- | --- | --- | --- | --- | --- | --- | --- | --- | --- | --- | --- | --- | --- | --- | --- | --- | --- | --- | --- | --- | --- | --- | --- | --- | --- | --- | --- | --- | --- | --- | --- | --- | --- | --- | --- | --- | --- | --- | --- | --- | --- | --- |
| 242231385 |  | Testing External magnetic shields |  | 25d | 2014-12-17 | 2015-02-02 | 242231325, 242231285 FS-120d |  |  |  | 173d | 128d | 8/5 M-F w/JLAB Holidays ReBaseline | SCIENTIST [192 h]; MECH TECH [192 h] | 23,520 |  | 242231385 | 0 | IN | ELOUADRHIRI L | 1 | 1 | U | LATIFA E | 09-030 | 11-026 | 12-007 | 12-027 | 12-054 | 13-002F | PE | 13-015 | PR | 14-001 |  |  |  |  |  |  |  |  |  |  |  |  |  |  |  |  |  |  |  |  |  |  |  |  |
| 242231370 |  | Assembling of the CTOF splitters |  | 40d | 2015-02-13 | 2015-04-09 | 242231360 |  |  |  | 81d | 36d | 8/5 M-F w/JLAB Holidays ReBaseline | ELEC TECH [80 h]; VISTNG USERS [80 h]; SCIENTIST [80 h] | 11,420.8 |  | 242231370 | 0 | IN | ELOUADRHIRI L | 1 | 1 | U | LATIFA E | 09-030 | 11-026 | 12-007 |  |  | 13-002F | PE | 13-015 | PR | 14-001 |  |  |  |  |  |  |  |  |  |  |  |  |  |  |  |  |  |  |  |  |  |  |  |  |
| 242231365 |  | Assembling of the CTOF patch panels |  | 30d | 2015-02-27 | 2015-04-09 | 242231355 |  |  |  | 81d | 36d | 8/5 M-F w/JLAB Holidays ReBaseline | ELEC TECH [80 h]; VISTNG USERS [80 h]; SCIENTIST [40 h] | 8,413.6 |  | 242231365 | 0 | IN | ELOUADRHIRI L | 1 | 1 | U | LATIFA E | 09-030 | 11-026 | 12-007 |  |  | 13-002F | PE | 13-015 | PR | 14-001 |  |  |  |  |  |  |  |  |  |  |  |  |  |  |  |  |  |  |  |  |  |  |  |  |
| 242231410 |  | CTOF in Storage Rack cabling |  | 33d | 2015-03-18 | 2015-05-01 | 242231335 FS-10d, 242231285 FS-100d, 242231305 FS+10d, 242231245, 242231340 |  |  |  | 45d | 0d | 8/5 M-F w/JLAB Holidays ReBaseline | SCIENTIST [80 h]; MECH TECH [40 h] | 7,907.2 |  | 242231410 | 0 | IN | ELOUADRHIRI L | 1 | 1 | U | LATIFA E | 09-030 | 11-026 | 12-007 |  | 12-054 | 13-002F | PE | 13-015 | PR | 14-001 |  |  |  |  |  |  |  |  |  |  |  |  |  |  |  |  |  |  |  |  |  |  |  |  |
| 242231415 |  | Assemble the DAQ system |  | 25d | 2015-03-30 | 2015-05-01 | 242231410 FS-25d |  |  |  | 45d | 0d | 8/5 M-F w/JLAB Holidays ReBaseline | SCIENTIST [96 h] | 7,217.28 |  | 242231415 | 0 | IN | ELOUADRHIRI L | 1 | 1 | H | LATIFA E | 09-030 | 11-026 | 12-007 |  |  | 13-002F | PE | 13-015 | PR | 14-001 | 12-053 |  |  |  |  |  |  |  |  |  |  |  |  |  |  |  |  |  |  |  |  |  |  |  |
| 242231420 |  | Standalone CTOF testing/optimizing |  | 29d | 2015-05-04 | 2015-06-15 | 242231410, 242231390, 242231255 FS+29d, 242231120 FS-65d, 242231250, 242231395, 242231415, 242231370 FS-20d, 242231405, 242231400, 242231115 FS-65d, 242231200, 242231245 FS+29d, 242231365 FS-20d |  |  |  | 45d | 0d | 8/5 M-F w/JLAB Holidays ReBaseline | SCIENTIST [64 h]; MECH TECH [12 h] | 5,379.36 |  | 242231420 | 0 |  | ELOUADRHIRI L | 1 | 1 | H | LATIFA E |  | 11-026 | 12-007 |  | 12-054 | 13-002F | PE | 13-015 | PR | 14-001 |  |  |  |  |  |  |  |  |  |  |  |  |  |  |  |  |  |  |  |  |  |  |  |  |
| 242231425 |  | Prepare CTOF-in-Storage-Rack for transportation |  | 35d | 2015-06-16 | 2015-08-04 | 242231265 FS-15d, 242231385 FS-35d, 242231420, 242231275 FS-35d |  |  |  | 45d | 0d | 8/5 M-F w/JLAB Holidays ReBaseline | VISTNG USERS [120 h]; MECH TECH [120 h]; SCIENTIST [120 h] | 17,170.8 |  | 242231425 | 0 |  | ELOUADRHIRI L | 1 | 1 | S | LATIFA E |  | 11-026 | 12-007 | 12-027 | 12-054 | 13-002F | PE | 13-015 | PR | 14-001 |  | ST |  |  |  |  |  |  |  |  |  |  |  |  |  |  |  |  |  |  |  |  |  |  |
| 242231470M |  | CTOF Ready for Installation | milestone | 0d | 2015-08-04 | 2015-08-04 | 242231430, 242231013E, 242231425 |  |  |  | 45d | 0d | 8/5 M-F w/JLAB Holidays ReBaseline |  |  |  | 242231470M | 0 |  | ELOUADRHIRI L | 1 | 1 | M | LATIFA E |  | 11-026 | 12-007 | 12-027 | 12-054 | 13-002F |  | 13-015 | PR |  |  |  |  |  |  |  |  |  |  |  |  |  |  |  |  |  |  |  |  |  |  |  |  |  |
|  | 2 | **1.4.2.2.3.2 FORWARD TOF** |  |  | 2009-10-06 | 2014-05-30 |  |  |  |  |  |  |  |  |  |  |  |  |  |  |  |  |  |  |  |  |  |  |  |  |  |  |  |  |  |  |  |  |  |  |  |  |  |  |  |  |  |  |  |  |  |  |  |  |  |  |  |  |
| 142232005 |  | FTOF-P-#1 Prcrmnt of Scintillator Matrl & Light Guides |  | 5d | 2009-10-06 A | 2009-10-12 A | 1222232030, 12222060, 12222065, 9-100M | 100% |  |  |  |  |  |  |  |  |  | 0 |  | ELOUADRHIRI L | 1 | 1 | Z | LATIFA E |  | 11-026 |  |  |  |  |  |  |  |  |  |  | 10-017 | 11-021 | 11 -035 |  |  |  |  |  |  |  |  |  |  |  |  |  |  |  |  |  |  |  |
| 142232010 |  | FTOF-P-#1 Prcrmnt of PMTs & Hi Voltage Dividers |  | 5d | 2009-10-06 A | 2009-10-12 A | 12222070, 9-100M | 100% |  |  |  |  |  |  |  |  |  | 0 |  | ELOUADRHIRI L | 1 | 1 | Z | LATIFA E |  | 11-026 |  |  |  |  |  |  |  |  |  |  | 10-017 | 11-021 | 11 -035 |  |  |  |  |  |  |  |  |  |  |  |  |  |  |  |  |  |  |  |
| 142232015 |  | FTOF-P-#1 Vend Fab of Scintillator Matrl & Light Guides Original Labor |  | 22d | 2010-06-01 A | 2010-06-30 A | 142232005 | 100% |  |  |  |  |  | SCIENTIST [80 h] | 5,304.8 | 5,304.8 |  | 5304.8 |  | ELOUADRHIRI L | 1 | 1 | H | LATIFA E |  | 11-026 |  |  |  |  |  |  |  |  |  |  | 10-017 | 11-021 | 11 -035 | 0 | APP | 08-045 |  |  |  |  |  |  |  |  |  |  |  |  |  |  |  |  |
| 142232025 |  | FTOF - P#1 QA of Scintillators and PMTs (Original Labor) |  | 22d | 2010-06-01 A | 2010-06-30 A | 9-100M FS+142d | 100% |  |  |  |  |  | PD UNIV STUDNT [13.33 h]; MECH DES [1.35 h]; ELEC TECH [4 h]; MECH TECH [14.65 h]; VISTNG USERS [40 h]; SCIENTIST [8 h] | 2,228.41 | 2,228.41 |  | 2228.4116 |  | ELOUADRHIRI L | 1 | 1 | H | LATIFA E |  | 11-026 |  |  |  |  |  |  |  |  |  |  | 10-017 | 11-021 | 11 -035 | 0 |  |  |  |  |  |  |  |  |  |  |  |  |  |  |  |  |  |  |
| 142232165 |  | FTOF Travel FY10 |  | 86d | 2010-06-01 A | 2010-09-30 A | 9-100M FS+162d | 100% |  |  |  |  |  | TRAVEL | 2,000 |  |  | 2000 |  | ELOUADRHIRI L | 1 | 1 | E | LATIFA E |  | 11-026 |  |  |  |  |  |  |  |  |  |  | 10-017 | 11-021 | 11 -035 | 0 |  |  | 100 | 100 |  |  |  |  |  |  |  |  |  |  |  |  |  |  |
| 142232205 |  | PMT /Divider Procurement Prep FY10 |  | 106.2d | 2010-06-01 A | 2010-10-29 A | 142232200M FS-20d | 100% |  |  |  |  |  | SCIENTIST [63.7 h] | 4,249.63 | 4,249.64 |  | 4223.947 |  | ELOUADRHIRI L | 1 | 1 | H | LATIFA E |  | 11-026 | 12-007 |  |  |  |  |  |  |  |  |  | 10-017 | 11-021 | 11 -035 | 0 |  |  |  |  | 11-001 |  |  |  |  |  |  |  |  |  |  |  |  |  |
| 142232205a |  | PMT /Divider Procurement Prep FY11 |  | 106.08d | 2010-06-01 A | 2010-10-29 A | 142232200M FS-20d, 142232205 | 100% |  |  |  |  |  | SCIENTIST [16.3 h] | 1,087.39 | 1,087.39 |  | 1115.409 |  | ELOUADRHIRI L | 1 | 1 | H | LATIFA E |  | 11-026 | 12-007 |  |  |  |  |  |  |  |  |  | 10-017 | 11-021 | 11 -035 | 0 |  |  |  |  | 11-001 |  |  |  |  |  |  |  |  |  |  |  |  |  |
| 142232310 |  | Preparation of USC construction contract |  | 159d | 2010-06-01 A | 2011-01-24 A | 142232200M FS-10d | 100% |  |  |  |  |  |  |  |  |  | 0 |  | ELOUADRHIRI L | 1 | 1 | H | LATIFA E |  | 11-026 |  |  |  |  |  |  |  |  |  |  | 10-017 |  | 11 -035 |  |  |  |  |  |  |  |  |  |  |  |  |  |  |  |  |  |  |  |
| 142232330 |  | Complete design of panel-1b support FY10 |  | 178d | 2010-06-01 A | 2011-02-21 A | 142232200M FS-100d | 100% | 2010-06-01 | 2011-02-18 |  |  |  | MECH DES [141.83 h]; MECH ENG [70.91 h] | 11,191.37 | 11,268.34 |  | 11085.8127 |  | ELOUADRHIRI L | 1 | 1 | H | LATIFA E |  | 11-026 |  |  |  |  |  |  |  |  |  |  | 10-017 | 11-021 | 11 -035 | 0 |  |  |  |  | 11-001 |  |  |  |  |  |  |  |  |  |  |  |  |  |
| 142232330a |  | Complete design of panel-1b support FY11 |  | 269.93d | 2010-06-01 A | 2011-06-30 A | 142232330 | 100% |  |  |  |  |  | MECH DES [18.17 h]; MECH ENG [9.09 h] | 1,438.42 | 1,451.42 |  | 1465.8411 |  | ELOUADRHIRI L | 1 | 1 | H | LATIFA E |  | 11-026 |  |  |  |  |  |  |  |  |  |  | 10-017 | 11-021 | 11 -035 | 0 |  |  |  |  | 11-001 |  |  |  |  |  |  |  |  |  |  |  |  |  |
| 142232340 |  | Finalize panel-1b scintillator lengths |  | 107d | 2010-06-01 A | 2010-10-29 A | 142232200M FS-50d | 100% |  |  |  |  |  | MECH ENG [40 h]; MECH DES [80 h] | 6,275.81 | 6,292.3 |  | 6253.2 |  | ELOUADRHIRI L | 1 | 1 | H | LATIFA E |  | 11-026 |  |  |  |  |  |  |  |  |  |  | 10-017 | 11-021 | 11 -035 | 0 |  |  |  |  |  | 11-032 |  |  |  |  |  |  |  |  |  |  |  |  |
| 142232365 |  | PMT Study Procurement |  | 65d | 2010-06-01 A | 2010-08-31 A | 142232200M FS-10d | 100% |  |  |  |  |  | PROCUREMENT<$50K 60 | 10,000 |  |  | 10000 |  | ELOUADRHIRI L | 1 | 1 | P | LATIFA E |  | 11-026 |  |  |  |  |  |  |  |  |  |  | 10-017 | 11-021 | 11 -035 | 0 |  |  |  |  |  |  | 0 | 10000 | 1000000 | 100 |  |  |  |  |  |  |  |  |
| 142232370 |  | PMT Studies at JLAB FY10 |  | 83d | 2010-06-01 A | 2010-09-27 A | 142232365 FS-86d | 100% |  |  |  |  |  | SCIENTIST [143.33 h] | 9,504.21 | 9,504.21 |  | 9504.2123 |  | ELOUADRHIRI L | 1 | 1 | H | LATIFA E |  | 11-026 |  |  |  |  |  |  |  |  |  |  | 10-017 | 11-021 | 11 -035 | 0 |  |  |  |  | 11-001 |  |  |  |  |  |  |  |  |  |  |  |  |  |
| 142232370a |  | PMT Studies at JLAB FY11 |  | 83d | 2010-06-01 A | 2010-09-27 A | 142232370 | 100% |  |  |  |  |  | SCIENTIST [96.67 h] | 6,410.19 | 6,410.19 |  | 6615.1281 |  | ELOUADRHIRI L | 1 | 1 | H | LATIFA E |  | 11-026 |  |  |  |  |  |  |  |  |  |  | 10-017 | 11-021 | 11 -035 | 0 |  |  |  |  | 11-001 |  |  |  |  |  |  |  |  |  |  |  |  |  |
| 142232160 |  | Final Drawings |  | 187d | 2010-06-28 A | 2011-03-31 A | 9-100M FS+162d | 100% |  |  |  |  |  | SCIENTIST [152 h]; MECH ENG [152 h] | 20,499.94 | 20,499.94 |  | 20088.32 |  | ELOUADRHIRI L | 1 | 1 | H | LATIFA E |  | 11-026 |  |  | 12-054F |  |  |  |  |  |  |  | 10-017 | 11-021 | 11 -035 | 0 |  |  |  |  |  |  |  |  |  |  |  |  |  |  |  |  |  |  |
| 142232230 |  | Scintillator Procurement Prep - Labor FY10 |  | 121.45d | 2010-06-28 A | 2010-12-20 A | 142232200M FS-10d | 100% |  |  |  |  |  | SCIENTIST [29.77 h] | 2,002.35 | 2,002.35 |  | 1974.0487 |  | ELOUADRHIRI L | 1 | 1 | H | LATIFA E |  | 11-026 |  |  |  |  |  |  |  |  |  |  | 10-017 | 11-021 | 11 -035 | 0 |  |  |  |  | 11-001 | 11-032 |  |  |  |  |  |  |  |  |  |  |  |  |
| 142232230a |  | Scintillator Procurement Prep - Labor FY11 |  | 122d | 2010-06-28 A | 2010-12-20 A | 142232230 | 100% |  |  |  |  |  | SCIENTIST [10.23 h] | 688.13 | 688.13 |  | 700.0389 |  | ELOUADRHIRI L | 1 | 1 | H | LATIFA E |  | 11-026 |  |  |  |  |  |  |  |  |  |  | 10-017 | 11-021 | 11 -035 | 0 |  |  |  |  | 11-001 | 11-032 |  |  |  |  |  |  |  |  |  |  |  |  |
| 142232350 |  | Complete panel-1b manufacturing drawings |  | 227d | 2010-08-02 A | 2011-06-30 A | 9-100M FS+205d | 100% |  |  |  |  |  | MECH ENG [80 h]; MECH DES [160 h] | 12,693.16 | 12,829.34 |  | 12506.4 |  | ELOUADRHIRI L | 1 | 1 | H | LATIFA E |  | 11-026 | 12-007 |  | 12-054F |  |  |  |  |  |  |  | 10-017 | 11-021 | 11 -035 | 0 |  |  |  |  |  | 11-032 |  |  |  |  |  |  |  |  |  |  |  |  |
| 142232170 |  | FTOF Travel FY11 |  | 248d | 2010-10-01 A | 2011-09-30 A | 142232165 | 100% |  |  |  |  |  | TRAVEL | 4,127.6 |  |  | 4127.6 |  | ELOUADRHIRI L | 1 | 1 | E | LATIFA E |  | 11-026 |  |  |  |  |  |  |  |  |  |  | 10-017 | 11-021 | 11 -035 | 0 |  |  | 100 | 100 |  |  |  |  |  |  | 8.46774193 | 91.53225806 |  |  |  |  |  |  |
| 142232200M |  | FTOF Construction Milestone | milestone | 0d | 2010-12-01 A | 2010-12-01 A | 9-100M FS+162d, 142232160 FS-40d | 100% | 2011-01-04 | 2011-01-04 |  |  |  |  |  |  |  | 0 |  | ELOUADRHIRI L | 1 | 1 | M | LATIFA E |  | 11-026 |  |  | 12-054F |  |  |  |  |  |  |  | 10-017 | 11-021 | 11 -035 |  |  |  |  |  |  |  |  |  |  |  |  |  |  |  |  |  |  |  |
| 142232220 |  | Vend Fab PMT /Divider Peg Point #1 First Articles (Qty. 6) |  | 32d | 2010-12-01 A | 2011-01-24 A | 142232205a FS+19d | 100% |  |  |  |  |  | PROCUREMENT<$50K 60 NO ESCALATION | 4,968 |  |  | 4968 |  | ELOUADRHIRI L | 1 | 1 | D | LATIFA E |  | 11-026 |  |  |  |  |  |  |  |  |  |  | 10-017 | 11-021 | 11 -035 | 0 |  |  |  |  |  |  | 0 | 4968 | 496800 | 100 |  |  | 11-009 |  |  |  |  |  |
| 142232221 |  | Vend Fab PMT /Divider Peg Point #2 Production Delivery #1 (Qty. 133) |  | 186d | 2010-12-01 A | 2011-09-01 A | 142232220 FS-37d | 100% | 2010-12-01 | 2011-08-31 |  |  |  | PROCUREMENT>$50K 69 NO ESCALATION; PROCUREMENT<$50K 60 NO ESCALATION | 110,124 |  |  | 110124 |  | ELOUADRHIRI L | 1 | 1 | D | LATIFA E |  | 11-026 |  |  |  |  |  |  |  |  |  |  | 10-017 | 11-021 | 11 -035 | 0 |  |  |  |  |  |  | 0 | 110124 | 11012400 | 100 |  |  | 11-009 |  |  |  |  |  |
| 142232222 |  | Vend Fab PMT /Divider Peg Point #3 Production Delivery #2 (Qty. 133) |  | 229d | 2010-12-01 A | 2011-11-01 A | 142232221 FS-163d | 100% |  |  |  |  |  | PROCUREMENT>$50K 69 NO ESCALATION | 110,124 |  |  | 110124 |  | ELOUADRHIRI L | 1 | 1 | D | LATIFA E |  | 11-026 |  |  |  |  |  |  |  |  |  |  | 10-017 | 11-021 | 11 -035 | 0 |  |  |  |  |  |  | 0 | 110124 | 11012400 | 100 |  |  | 11-009 |  |  |  |  |  |
| 142232223 |  | Vend Fab PMT /Divider Peg Point #4 Production Delivery #3 (Qty. 134) |  | 280d | 2010-12-01 A | 2012-01-24 A | 142232222 FS-228d | 100% |  |  |  |  |  | PROCUREMENT>$50K 69 NO ESCALATION | 110,952 |  |  | 110952 |  | ELOUADRHIRI L | 1 | 1 | D | LATIFA E |  | 11-026 |  |  |  |  |  |  |  |  |  |  | 10-017 | 11-021 | 11 -035 | 0 |  |  |  |  |  |  | 0 | 110952 | 11095200 | 100 |  |  | 11-009 |  |  |  |  |  |
| 142232270 |  | Backing Support Procurement Prep - Labor FY10 |  | 38d | 2010-12-20 A | 2011-02-21 A | 142232200M | 100% | 2010-12-20 | 2011-02-18 |  |  |  | SCIENTIST [22.7 h] | 1,553.36 | 1,553.36 |  | 1505.237 |  | ELOUADRHIRI L | 1 | 1 | H | LATIFA E |  | 11-026 |  |  |  |  |  |  |  |  |  |  | 10-017 | 11-021 | 11 -035 | 0 |  |  |  |  | 11-001 | 11-032 |  |  |  |  |  |  |  |  |  |  |  |  |
| 142232270a |  | Backing Support Procurement Prep - Labor FY11 |  | 43d | 2010-12-20 A | 2011-02-28 A | 142232270 FS-100d, 142232200M | 100% |  |  |  |  |  | SCIENTIST [17.3 h] | 1,183.84 | 1,183.84 |  | 1183.839 |  | ELOUADRHIRI L | 1 | 1 | H | LATIFA E |  | 11-026 |  |  |  |  |  |  |  |  |  |  | 10-017 | 11-021 | 11 -035 | 0 |  |  |  |  | 11-001 | 11-032 |  |  |  |  |  |  |  |  |  |  |  |  |
| 142232355 |  | Complete Design of Panel-1a Frame Modification Pieces |  | 144d | 2011-02-01 A | 2011-08-24 A | 142232200M | 100% |  |  |  |  |  | MECH ENG [40 h]; MECH DES [80 h] | 6,452.4 | 6,452.4 |  | 6452.4 |  | ELOUADRHIRI L | 1 | 1 | H | LATIFA E |  | 11-026 | 12-007 |  |  |  |  |  |  |  |  |  | 10-017 | 11-021 | 11 -035 | 0 |  |  |  |  |  | 11-032 |  |  |  |  |  |  |  |  |  |  |  |  |
| 142232315M |  | Award USC Contract | milestone | 0d | 2011-02-14 A | 2011-02-14 A | 142232310 FS+120d | 100% | 2011-03-01 | 2011-03-01 |  |  |  |  |  |  |  | 0 |  | ELOUADRHIRI L | 1 | 1 | M | LATIFA E |  | 11-026 |  |  |  |  |  |  |  |  |  |  | 10-017 | 11-021 | 11 -035 |  |  |  |  |  |  |  |  |  |  |  |  |  |  |  |  |  |  |  |
| 142232360 |  | Complete design of panel-2 support |  | 287d | 2011-02-21 A | 2012-04-16 A | 142232200M | 100% | 2011-02-22 | 2012-04-16 |  |  |  | MECH ENG [180 h]; MECH DES [540 h] | 37,805.46 | 37,983.75 |  | 38633.4 |  | ELOUADRHIRI L | 1 | 1 | H | LATIFA E |  | 11-026 | 12-007 |  |  |  |  |  |  |  |  |  | 10-017 | 11-021 | 11 -035 | 0 |  |  |  |  |  | 11-032 |  |  |  |  |  |  |  | 11-038 |  |  |  |  |
| 142232320 |  | Peg Point #1 - Set up Assembly Space at USC |  | 40d | 2011-03-01 A | 2011-04-25 A | 142232315M | 100% |  |  |  |  |  | PROCUREMENT<$50K 60 NO ESCALATION | 35,617.37 |  |  | 35617.37 |  | ELOUADRHIRI L | 1 | 1 | D | LATIFA E |  | 11-026 |  |  |  |  |  |  |  |  |  |  | 10-017 | 11-021 | 11 -035 | 0 |  |  |  |  |  |  | 0 | 35617.37 | 3561737 | 100 |  |  |  |  |  |  |  |  |
| 142232320A |  | Peg Point #2 - Readiness review at USC |  | 17d | 2011-04-01 A | 2011-04-25 A | 142232320 FS-21d | 100% |  |  |  |  |  | PROCUREMENT<$50K 60 NO ESCALATION | 8,321.9 |  |  | 8321.9 |  | ELOUADRHIRI L | 1 | 1 | D | LATIFA E |  | 11-026 |  |  |  |  |  |  |  |  |  |  | 10-017 | 11-021 | 11 -035 | 0 |  |  |  |  |  |  | 0 | 8321.9 | 832190 | 100 |  |  |  |  |  |  |  |  |
| 142232320B |  | Peg Point #3 - PMT/divider testing start |  | 16d | 2011-04-02 A | 2011-04-25 A | 142232320A FS-21d | 100% | 2011-04-04 | 2011-04-25 |  |  |  | PROCUREMENT<$50K 60 NO ESCALATION | 2,164.22 |  |  | 2164.22 |  | ELOUADRHIRI L | 1 | 1 | D | LATIFA E |  | 11-026 |  |  |  |  |  |  |  |  |  |  | 10-017 | 11-021 | 11 -035 | 0 |  |  |  |  |  |  | 0 | 2164.22 | 216422 | 100 |  |  |  |  |  |  |  |  |
| 142232320C |  | Peg Point #4 - Scintillator testing start |  | 98d | 2011-04-02 A | 2011-08-20 A | 142232320B FS-21d | 100% | 2011-04-04 | 2011-08-19 |  |  |  | PROCUREMENT>$50K 69 NO ESCALATION; PROCUREMENT<$50K 60 NO ESCALATION | 21,878.08 |  |  | 21878.08 |  | ELOUADRHIRI L | 1 | 1 | D | LATIFA E |  | 11-026 |  |  |  |  |  |  |  |  |  |  | 10-017 | 11-021 | 11 -035 | 0 |  |  |  |  |  |  | 0 | 21878.08 | 2187808 | 100 |  |  |  |  |  |  |  |  |
| 142232320D |  | Peg Point #5 - Phase 1 assembly start (first 5units) |  | 163d | 2011-04-02 A | 2011-11-21 A | 142232320C FS-70d | 100% | 2011-04-04 | 2011-11-21 |  |  |  | PROCUREMENT>$50K 69 NO ESCALATION | 64,435.89 |  |  | 64435.89 |  | ELOUADRHIRI L | 1 | 1 | D | LATIFA E |  | 11-026 |  |  |  |  |  |  |  |  |  |  | 10-017 | 11-021 | 11 -035 | 0 |  |  |  |  |  |  | 0 | 64435.89 | 6443589 | 100 |  |  |  |  |  |  |  |  |
| 142232320F |  | Peg Point #6A - Phase 2 assembly start (next 42 units) Part 1 |  | 199d | 2011-04-02 A | 2012-01-23 A | 142232320D FS-189d | 100% | 2011-04-04 | 2012-01-23 |  |  |  | PROCUREMENT>$50K 69 NO ESCALATION | 25,215.57 |  |  | 25215.57 |  | ELOUADRHIRI L | 1 | 1 | D | LATIFA E |  | 11-026 |  |  |  |  |  |  |  |  |  |  | 10-017 | 11-021 | 11 -035 | 0 |  |  |  |  |  |  | 0 | 25215.57 | 2521557 | 100 |  |  |  |  |  |  |  |  |
| 142232240 |  | Phase 1a FRT (BC-404) first article (3 ea) |  | 33d | 2011-04-14 A | 2011-05-31 A | 142232230a, 142232340 FS-400d | 100% |  |  |  |  |  | PROCUREMENT<$50K 60 NO ESCALATION | 3,096 |  |  | 3096 |  | ELOUADRHIRI L | 1 | 1 | D | LATIFA E |  | 11-026 |  |  |  |  |  |  |  |  |  |  | 10-017 | 11-021 | 11 -035 | 0 |  |  |  |  |  | 11-032 | 0 | 3096 | 309600 | 100 |  |  |  |  |  |  |  |  |
| 142232241 |  | Phase 1b LAL (BC-408) first article (3 ea) |  | 33d | 2011-04-14 A | 2011-05-31 A | 142232240 FS-33d | 100% |  |  |  |  |  | PROCUREMENT<$50K 60 NO ESCALATION | 2,508 |  |  | 2508 |  | ELOUADRHIRI L | 1 | 1 | D | LATIFA E |  | 11-026 |  |  |  |  |  |  |  |  |  |  | 10-017 | 11-021 | 11 -035 | 0 |  |  |  |  |  | 11-032 | 0 | 2508 | 250800 | 100 |  |  |  |  |  |  |  |  |
| 142232242 |  | Phase 1c FRT (BC-404) 72 bars |  | 66d | 2011-04-14 A | 2011-07-18 A | 142232241 FS-33d | 100% |  |  |  |  |  | PROCUREMENT<$50K 60 NO ESCALATION | 29,971.44 |  |  | 29971.44 |  | ELOUADRHIRI L | 1 | 1 | D | LATIFA E |  | 11-026 |  |  |  |  |  |  |  |  |  |  | 10-017 | 11-021 | 11 -035 | 0 |  |  |  |  |  | 11-032 | 0 | 29971.44 | 2997144 | 100 |  |  |  |  |  |  |  |  |
| 142232243 |  | Phase 1d FRT (BC-404) 90 bars |  | 104d | 2011-04-14 A | 2011-09-12 A | 142232242 FS-98d | 100% | 2011-04-14 | 2011-09-09 |  |  |  | PROCUREMENT>$50K 69 NO ESCALATION; PROCUREMENT<$50K 60 NO ESCALATION | 37,464.3 |  |  | 37464.3 |  | ELOUADRHIRI L | 1 | 1 | D | LATIFA E |  | 11-026 |  |  |  |  |  |  |  |  |  |  | 10-017 | 11-021 | 11 -035 | 0 |  |  |  |  |  | 11-032 | 0 | 37464.3 | 3746430 | 100 |  |  |  |  |  |  |  |  |
| 142232244 |  | Phase 1e FRT (BC-404) 24 bars |  | 114d | 2011-04-14 A | 2011-09-26 A | 142232243 FS-140d | 100% | 2011-04-14 | 2011-09-23 |  |  |  | PROCUREMENT>$50K 69 NO ESCALATION | 9,990.48 |  |  | 9990.48 |  | ELOUADRHIRI L | 1 | 1 | D | LATIFA E |  | 11-026 |  |  |  |  |  |  |  |  |  |  | 10-017 | 11-021 | 11 -035 | 0 |  |  |  |  |  | 11-032 | 0 | 9990.48 | 999048 | 100 |  |  |  |  |  |  |  |  |
| 142232280 |  | Backing Support Phase 1 Delivery |  | 106d | 2011-05-02 A | 2011-09-30 A | 142232270, 142232270a | 100% | 2011-05-02 | 2011-09-29 |  |  |  | PROCUREMENT>$50K 69 NO ESCALATION FY12; PROCUREMENT<$50K 60 NO ESCALATION FY12 | 75,114 |  |  | 75114 |  | ELOUADRHIRI L | 1 | 1 | D | LATIFA E |  | 11-026 |  |  |  |  |  |  |  |  |  |  | 10-017 | 11-021 | 11 -035 | 0 |  |  |  |  |  | 11-032 | 0 | 75114 | 7511400 | 100 |  |  |  |  |  |  |  |  |
| 142232352 |  | Panel 1-a/1-b Installation tooling labor |  | 46d | 2011-06-01 A | 2011-08-04 A | 142232350 FS-5d | 100% |  |  |  |  |  | MECH DES [40 h]; MECH ENG [20 h] | 3,226.2 | 3,226.2 |  | 3226.2 |  | ELOUADRHIRI L | 1 | 1 | H | LATIFA E |  | 11-026 | 12-007 |  | 12-054F |  |  |  |  |  |  |  | 10-017 | 11-021 | 11 -035 | 0 |  |  |  |  |  | 11-032 |  |  |  |  |  |  |  |  |  |  |  |  |
| 142232356 |  | Final Panel 1-a/1-b manufacturing support FY11 |  | 28d | 2011-07-18 A | 2011-08-24 A | 142232355 FS-44d | 100% |  |  |  |  |  | MECH ENG [98.79 h]; MECH DES [237.1 h] | 17,780.61 | 17,780.61 |  | 17780.6085 |  | ELOUADRHIRI L | 1 | 1 | H | LATIFA E |  | 11-026 | 12-007 |  |  |  |  |  |  |  |  |  | 10-017 | 11-021 | 11 -035 | 0 |  |  |  |  |  | 11-032 |  |  |  |  |  |  |  |  | 12-001 |  |  |  |
| 142232356a |  | Final Panel 1-1/1-b manufacturing support FY12 |  | 28d | 2011-07-18 A | 2011-08-24 A | 142232356 | 100% |  |  |  |  |  | MECH ENG [1.21 h]; MECH DES [2.9 h] | 217.59 | 217.59 |  | 224.5382 |  | ELOUADRHIRI L | 1 | 1 | H | LATIFA E |  | 11-026 | 12-007 |  |  |  |  |  |  |  |  |  | 10-017 | 11-021 | 11 -035 | 0 |  |  |  |  |  | 11-032 |  |  |  |  |  |  |  |  | 12-001 |  |  |  |
| 142232380 |  | PMT/Divider Procurement Prep - Labor |  | 10d | 2011-09-12 A | 2011-09-26 A | 142232375M | 100% | 2011-09-12 | 2011-09-23 |  |  |  | SCIENTIST [40 h] | 2,737.2 | 2,737.2 |  | 2824.4 |  | ELOUADRHIRI L | 1 | 1 | H | LATIFA E |  | 11-026 |  |  |  |  |  |  |  |  |  |  | 10-017 | 11-021 | 11 -035 | 0 |  |  |  |  |  |  |  |  |  |  |  |  |  |  |  |  |  |  |
| 142232281 |  | Backing Support 1st Article Test |  | 8d | 2011-09-14 A | 2011-09-26 A | 142232280 FS-195d | 100% | 2011-09-14 | 2011-09-23 |  |  |  | MECH ENG [20 h]; MECH TECH [40 h] | 3,081.8 | 3,081.8 |  | 3081.8 |  | ELOUADRHIRI L | 1 | 1 | D | LATIFA E |  | 11-026 |  |  |  |  |  |  |  |  |  |  | 10-017 | 11-021 | 11 -035 | 0 |  |  |  |  |  | 11-032 |  |  |  |  |  |  |  |  |  |  |  |  |
| 142232175 |  | FTOF Travel FY12 |  | 247d | 2011-10-03 A | 2012-09-28 A | 142232170 | 100% |  |  |  |  |  | TRAVEL | 7,354.97 |  |  | 7354.97 |  | ELOUADRHIRI L | 1 | 1 | E | LATIFA E |  | 11-026 |  |  |  |  |  |  |  |  |  |  | 10-017 | 11-021 | 11 -035 | 0 |  |  | 100 | 100 |  | 11-032 |  |  |  |  | 7.69230769 | 92.3076923 |  |  |  |  |  |  |
| 142232245 |  | Phase 2a LAL (BC-408) 64 bars |  | 169d | 2011-10-03 A | 2012-06-11 A | 142232244 FS-58d | 100% |  |  |  |  |  | PROCUREMENT<$50K 60 NO ESCALATION | 44,262 |  |  | 44262 |  | ELOUADRHIRI L | 1 | 1 | D | LATIFA E |  | 11-026 |  |  |  |  |  |  |  |  |  |  | 10-017 | 11-021 | 11 -035 | 0 |  |  |  |  |  | 11-032 | 0 | 44262 | 4426200 | 100 |  |  |  |  |  |  |  |  |
| 142232246 |  | Phase 2b LAL (BC-408) 64 bars |  | 169d | 2011-10-03 A | 2012-06-11 A | 142232245 FS-98d | 100% |  |  |  |  |  | PROCUREMENT<$50K 60 NO ESCALATION; PROCUREMENT>$50K 69 NO ESCALATION | 44,262 |  |  | 44262 |  | ELOUADRHIRI L | 1 | 1 | D | LATIFA E |  | 11-026 |  |  |  |  |  |  |  |  |  |  | 10-017 | 11-021 | 11 -035 | 0 |  |  |  |  |  | 11-032 | 0 | 44262 | 4426200 | 100 |  |  |  |  |  |  |  |  |
| 142232247 |  | Phase 2c LAL (BC-408) 64 bars |  | 238d | 2011-10-03 A | 2012-09-17 A | 142232246 FS-141d | 100% |  |  |  |  |  | PROCUREMENT>$50K 69 NO ESCALATION | 44,261 |  |  | 44261 |  | ELOUADRHIRI L | 1 | 1 | D | LATIFA E |  | 11-026 |  |  |  |  |  |  |  |  |  |  | 10-017 | 11-021 | 11 -035 | 0 |  |  |  |  |  | 11-032 | 0 | 44261 | 4426100 | 100 |  |  |  |  |  |  |  |  |
| 142232225 |  | Vend Fab PMT /Divider Peg Point #5 Production Delivery #4 (Qty. 133) |  | 105d | 2011-11-01 A | 2012-04-09 A | 142232223 FS-40d | 100% |  |  |  |  |  | PROCUREMENT>$50K 69 NO ESCALATION; PROCUREMENT<$50K 60 NO ESCALATION | 104,671 |  |  | 104671 |  | ELOUADRHIRI L | 1 | 1 | D | LATIFA E |  | 11-026 |  |  |  |  |  |  |  |  |  |  | 10-017 | 11-021 | 11 -035 | 0 |  |  |  |  |  |  | 0 | 104671 | 10467100 | 100 |  |  | 11-009 |  |  |  |  |  |
| 142232226 |  | Vend Fab PMT /Divider Peg Point #6 Production Delivery #5 (Qty. 133) |  | 148d | 2011-11-01 A | 2012-06-11 A | 142232225 FS-80d | 100% |  |  |  |  |  | PROCUREMENT>$50K 69 NO ESCALATION | 104,671 |  |  | 104671 |  | ELOUADRHIRI L | 1 | 1 | D | LATIFA E |  | 11-026 |  |  |  |  |  |  |  |  |  |  | 10-017 | 11-021 | 11 -035 | 0 |  |  |  |  |  |  | 0 | 104671 | 10467100 | 100 |  |  | 11-009 |  |  |  |  |  |
| 142232227 |  | Vend Fab PMT /Divider Peg Point #7 Production Delivery #6 (Qty. 134) |  | 217d | 2011-11-01 A | 2012-09-17 A | 142232226 FS-143d | 100% |  |  |  |  |  | PROCUREMENT>$50K 69 NO ESCALATION | 105,458 |  |  | 105458 |  | ELOUADRHIRI L | 1 | 1 | D | LATIFA E |  | 11-026 |  |  |  |  |  |  |  |  |  |  | 10-017 | 11-021 | 11 -035 | 0 |  |  |  |  |  |  | 0 | 105458 | 10545800 | 100 |  |  | 11-009 |  |  |  |  |  |
| 142232285 |  | Backing Support Phase 2 Delivery |  | 33d | 2011-11-01 A | 2011-12-19 A | 142232280 FS-115d, 142232281 | 100% |  |  |  |  |  | PROCUREMENT<$50K 60 NO ESCALATION FY13; PROCUREMENT>$50K 69 NO ESCALATION FY13 | 77,510.14 |  |  | 77510.14 |  | ELOUADRHIRI L | 1 | 1 | D | LATIFA E |  | 11-026 |  |  |  |  |  |  |  |  |  |  | 10-017 | 11-021 | 11 -035 | 0 |  |  |  |  |  | 11-032 | 0 | 77510.14 | 7751014 | 100 |  |  |  |  |  |  |  |  |
| 142232306 |  | Panel-1b magnetic shields procurement prep. |  | 5d | 2011-11-01 A | 2011-11-07 A | 142232205a, 9-120M FS+21d | 100% |  |  |  |  |  | SCIENTIST [40 h] | 2,824.4 | 2,824.4 |  | 2824.4 |  | ELOUADRHIRI L | 1 | 1 | H | LATIFA E |  | 11-026 | 12-007 |  |  |  |  |  |  |  |  |  | 10-017 | 11-021 | 11 -035 | 0 |  |  |  |  |  |  |  |  |  |  |  |  |  |  |  | 11-056 |  |  |
| 142232307 |  | Panel-1b magnetic shields procurement |  | 198d | 2011-11-01 A | 2012-08-20 A | 142232306 | 100% |  |  |  |  |  | PROCUREMENT<$50K 60 NO ESCALATION FY13; PROCUREMENT>$50K 69 NO ESCALATION FY13 | 74,400 |  |  | 74400 |  | ELOUADRHIRI L | 1 | 1 | D | LATIFA E |  | 11-026 | 12-007 |  |  |  |  |  |  |  |  |  | 10-017 | 11-021 | 11 -035 | 0 |  |  |  |  |  |  | 0 | 74400 | 7440000 | 100 |  |  |  |  |  | 11-056 |  |  |
| 142232320G |  | Peg Point #6B - Phase 2 assembly start (next 42 units) Part 2 |  | 306d | 2011-11-01 A | 2013-01-31 A | 142232320F FS-57d | 100% |  |  |  |  |  | PROCUREMENT<$50K 60 NO ESCALATION; PROCUREMENT>$50K 69 NO ESCALATION | 115,492 |  |  | 115492 |  | ELOUADRHIRI L | 1 | 1 | D | LATIFA E |  | 11-026 |  |  |  |  |  |  |  |  |  |  | 10-017 | 11-021 | 11 -035 | 0 |  |  |  |  |  |  | 0 | 115492 | 11549200 | 100 |  |  |  |  |  |  | MP | XX |
| 142232361 |  | FTOF storage/work shelves final drawings |  | 66d | 2011-11-01 A | 2012-02-13 A | 9-120M FS+21d, 142232160 | 100% |  |  |  |  |  | MECH ENG [40 h]; MECH DES [80 h] | 6,658.4 | 6,658.4 |  | 6658.4 |  | ELOUADRHIRI L | 1 | 1 | H | LATIFA E |  | 11-026 | 12-007 |  | 12-054F |  |  |  |  |  |  |  | 10-017 | 11-021 | 11 -035 | 0 |  |  |  |  |  | 11-032 |  |  |  |  |  |  |  |  |  | 11-056 |  |  |
| 142232371 |  | Panel-1a/2 magnetic shield first article testing |  | 33d | 2011-11-01 A | 2011-12-19 A | 142232356a, 9-120M FS+21d | 100% |  |  |  |  |  | SCIENTIST [120 h] | 8,473.2 | 8,473.2 |  | 8473.2 |  | ELOUADRHIRI L | 1 | 1 | H | LATIFA E |  | 11-026 | 12-007 |  |  |  |  |  |  |  |  |  | 10-017 | 11-021 | 11 -035 | 0 |  |  |  |  | 11-001 |  |  |  |  |  |  |  |  |  |  | 11-056 |  |  |
| 142232375M |  | Panel 1a Preparation | milestone | 0d | 2011-11-01 A | 2011-11-01 A | 142232200M FS+265d | 100% | 2012-01-03 | 2012-01-03 |  |  |  |  |  |  |  | 0 |  | ELOUADRHIRI L | 1 | 1 | M | LATIFA E |  | 11-026 |  |  | 12-054F |  |  |  |  |  |  |  | 10-017 | 11-021 | 11 -035 |  |  |  |  |  |  | 11-032 |  |  |  |  |  |  |  |  |  |  |  |  |
| 142232385 |  | PMT/Divider Procurement |  | 129d | 2011-11-01 A | 2012-05-12 A | 142232380 | 100% | 2011-11-01 | 2012-05-11 |  |  |  | PROCUREMENT<$50K 60 | 38,333.43 |  |  | 38333.43 |  | ELOUADRHIRI L | 1 | 1 | D | LATIFA E |  | 11-026 |  |  |  |  |  |  |  |  |  |  | 10-017 | 11-021 | 11 -035 | 0 |  |  |  |  |  |  | 0 | 38333.43 | 3833343 | 100 |  |  |  |  |  |  |  |  |

Notes:
- 242231425: Steps: Rack #1; Rack #2; Rack #3; Rack #4; Rack #5; Rack #6
- 142232375M: Constraints and Assumptions: Based on Doug Tilles CLAS6 Deinstallation / Schedule.

| ID | Activity | Type | Duration | Start | Finish | Predecessors | Complete | Planned start | Planned finish | Resources | Cost | Actual cost | Remaining Material Cost Based on % Compl | Claimed Material Cost Based on % Complet | Initial Claimed Material Calc | Claimed Material Divider | Calculated Remaining Total Cost | MONTHLY EV COST | RESP - Responsibility | STRT%COMP for CM EVM | FNSH%COMP for CM EVM | EVMS Reporting Codes | CAM RESPONSIBLE | CR 10-017 | CR 11-021 | CR 11-026 | CR 11-032 | CR 11-035 | CR 12-007 | CR 12-054 | CR 11-001 | CR 11-056 | CR 12-018 | CR 13-006 | MARCH!!! | CR 12-027 | CR 12-053 | LOE % Pre Calc | LOE % | LOE Divider | LOE Multiplier |
| --- | --- | --- | --- | --- | --- | --- | --- | --- | --- | --- | --- | --- | --- | --- | --- | --- | --- | --- | --- | --- | --- | --- | --- | --- | --- | --- | --- | --- | --- | --- | --- | --- | --- | --- | --- | --- | --- | --- | --- | --- | --- |
| 142232353 | Panel 1-a/1-b Installation tooling Proc |  | 83d | 2011-12-12 A | 2012-04-16 A | 9-120M FS+50d, 142232352 | 100% |  |  | PROCUREMENT<$50K 60 | 5,000 |  | 0 | 5000 | 500000 | 100 | 0 | 5000 | ELOUADRHIRI L | 1 | 1 | H | LATIFA E | 10-017 | 11-021 | 11-026 | 11-032 | 11 -035 | 12-007 | 12-054F |  |  |  |  |  |  |  |  |  |  |  |
| 142232372 | Panel-1a/2 magnetic shields procurement prep. |  | 6d | 2011-12-12 A | 2011-12-19 A | 142232371 | 100% |  |  | SCIENTIST [80 h] | 5,648.8 | 5,648.8 |  |  |  |  | 0 | 5648.8 | ELOUADRHIRI L | 1 | 1 | H | LATIFA E | 10-017 | 11-021 | 11-026 |  | 11 -035 | 12-007 |  | 11-001 | 11-056 |  |  |  |  |  |  |  |  |  |
| 142232395 | Set up FTOF DAQ and Test Station |  | 288d | 2012-01-03 A | 2013-02-28 A | 142232375M FS+40d | 100% |  |  | SCIENTIST [400 h] | 28,553.38 | 28,553.38 |  |  |  |  | 0 | 28244 | ELOUADRHIRI L | 1 | 1 | H | LATIFA E | 10-017 | 11-021 | 11-026 | 11-032 | 11 -035 |  | 12-054F |  |  | 12-018F | 13-006F | XX |  |  |  |  |  |  |
| 142232362 | FTOF storage/work shelves - procurement prep. |  | 31d | 2012-02-01 A | 2012-03-16 A | 142232361 FS-11d | 100% | 2012-02-01 | 2012-03-15 | SCIENTIST [40 h] | 2,824.4 | 2,824.4 |  |  |  |  | 0 | 2824.4 | ELOUADRHIRI L | 1 | 1 | H | LATIFA E | 10-017 | 11-021 | 11-026 | 11-032 | 11 -035 | 12-007 | 12-054F |  | 11-056 |  |  |  |  |  |  |  |  |  |
| 142232390 | Misc. Counter Repair Parts |  | 353d | 2012-02-01 A | 2013-03-11 A | 142232375M FS+40d | 100% | 2012-02-01 | 2013-06-28 | PROCUREMENT<$50K 60 | 10,648.18 |  | 0 | 10648.18 | 1064818 | 100 | 0 | 10648.18 | ELOUADRHIRI L | 1 | 1 | D | LATIFA E | 10-017 | 11-021 | 11-026 |  | 11 -035 |  |  |  |  |  |  |  |  |  |  |  |  |  |
| 142232396 | Calibration test equipment Procurement |  | 251d | 2012-02-01 A | 2013-08-30 A | 142232375M FS+40d | 100% | 2012-02-01 | 2013-02-04 | PROCUREMENT<$50K 60 | 15,500 |  | 0 | 15500 | 1550000 | 100 | 2945 | 15500 | ELOUADRHIRI L | 1 | 1 | D | LATIFA E | 10-017 | 11-021 | 11-026 | 11-032 | 11 -035 | 12-007 |  |  | 11-056 |  |  | XX |  |  |  |  |  |  |
| 142232655 | Panel 2 Support Frame Procurement |  | 229d | 2012-02-01 A | 2013-08-30 A | 142232654 FS-90d, 142232565 FS-185d, 142232360 FS-110d | 100% | 2012-02-01 | 2013-01-02 | PROCUREMENT<$50K 60 NO ESCALATION FY13 | 47,423.03 |  | 0 | 47423.03 | 4742303 | 100 | 7113.4545 | 47423.03 | ELOUADRHIRI L | 1 | 1 | D | LATIFA E | 10-017 | 11-021 | 11-026 | 11-032 | 11 -035 |  |  |  |  |  |  | XX |  |  |  |  |  |  |
| 142232654 | Support frame procurement prep |  | 13d | 2012-03-01 A | 2012-03-19 A | 9-120M FS+174d | 100% |  |  | SCIENTIST [80 h] | 5,648.8 | 5,648.8 |  |  |  |  | 0 | 5648.8 | ELOUADRHIRI L | 1 | 1 | H | LATIFA E | 10-017 | 11-021 | 11-026 | 11-032 | 11 -035 |  |  |  |  |  |  |  |  |  |  |  |  |  |
| 142232549M | Panel 2 preparation | milestone | 0d | 2012-03-02 A | 2012-03-02 A | 9-120M FS+120d | 100% | 2012-04-02 | 2012-04-02 |  |  |  |  |  |  |  |  | 0 | ELOUADRHIRI L | 1 | 1 | M | LATIFA E | 10-017 | 11-021 | 11-026 | 11-032 | 11 -035 |  |  |  |  |  |  |  |  |  |  |  |  |  |
| 142232550 | PMT/Divider Procurement Prep - Labor |  | 70d | 2012-03-02 A | 2012-06-11 A | 142232200M, 142232549M | 100% |  |  | SCIENTIST [40 h] | 2,824.4 | 2,824.4 |  |  |  |  | 0 | 2824.4 | ELOUADRHIRI L | 1 | 1 | H | LATIFA E | 10-017 | 11-021 | 11-026 |  | 11 -035 |  |  |  |  |  |  |  |  |  |  |  |  |  |
| 142232363 | FTOF storage/work shelves - procurement |  | 46d | 2012-03-12 A | 2012-05-14 A | 142232362 | 100% |  |  | PROCUREMENT<$50K 60 | 27,000 |  | 0 | 27000 | 2700000 | 100 | 0 | 27000 | ELOUADRHIRI L | 1 | 1 | D | LATIFA E | 10-017 | 11-021 | 11-026 | 11-032 | 11 -035 | 12-007 | 12-054F |  | 11-056 |  |  |  |  |  |  |  |  |  |
| 142232373 | Panel-1a/2 magnetic shields procurement |  | 89d | 2012-04-16 A | 2012-08-20 A | 142232372 FS+85d | 100% |  |  | PROCUREMENT<$50K 60 NO ESCALATION FY13 | 15,500 |  | 0 | 15500 | 1550000 | 100 | 0 | 15500 | ELOUADRHIRI L | 1 | 1 | D | LATIFA E | 10-017 | 11-021 | 11-026 |  | 11 -035 | 12-007 |  | 11-001 | 11-056 |  |  |  |  |  |  |  |  |  |
| 142232520 | Frame Modification Support Piece Procurement |  | 128d | 2012-04-16 A | 2012-10-15 A | 142232375M, 142232356a, 142232355 | 100% |  |  | PROCUREMENT<$50K 60 | 16,481.78 |  | 0 | 16481.78 | 1648178 | 100 | 0 | 16481.78 | ELOUADRHIRI L | 1 | 1 | D | LATIFA E | 10-017 | 11-021 | 11-026 |  | 11 -035 |  |  |  |  |  |  |  |  |  |  |  |  |  |
| 142232354 | Installation tooling load testing |  | 11d | 2012-07-02 A | 2012-07-16 A | 9-120M FS+204d, 142232353 | 100% |  |  | MECH TECH [40 h] | 1,777.6 | 1,777.6 |  |  |  |  | 0 | 1777.6 | ELOUADRHIRI L | 1 | 1 | H | LATIFA E | 10-017 | 11-021 | 11-026 | 11-032 | 11 -035 | 12-007 | 12-054F |  | 11-056 |  |  |  |  |  |  |  |  |  |
| 142232555 | PMT/Divider Procurement |  | 127d | 2012-07-02 A | 2013-02-07 A | 142232550 | 100% | 2012-07-02 | 2013-01-07 | PROCUREMENT<$50K 60 | 39,556.27 |  | 0 | 39556.27 | 3955627 | 100 | 0 | 39556.27 | ELOUADRHIRI L | 1 | 1 | D | LATIFA E | 10-017 | 11-021 | 11-026 |  | 11 -035 |  |  |  |  |  |  | XX | 12-027 |  |  |  |  |  |
| 142232231 | Forward carriage patch panels procurement prep. |  | 14d | 2012-08-01 A | 2012-08-20 A | 142232160, 9-130M | 100% |  |  | SCIENTIST [40 h] | 2,824.4 | 2,824.4 |  |  |  |  | 0 | 2914.4 | ELOUADRHIRI L | 1 | 1 | H | LATIFA E | 10-017 | 11-021 | 11-026 | 11-032 | 11 -035 | 12-007 |  | 11-001 | 11-056 |  |  |  |  |  |  |  |  |  |
| 142232233 | Patch panel to electronics cables procurement prep. |  | 14d | 2012-08-01 A | 2012-08-20 A | 9-130M, 142232160 | 100% |  |  | SCIENTIST [40 h] | 2,824.4 | 2,824.4 |  |  |  |  | 0 | 2914.4 | ELOUADRHIRI L | 1 | 1 | H | LATIFA E | 10-017 | 11-021 | 11-026 | 11-032 | 11 -035 | 12-007 |  | 11-001 | 11-056 |  |  |  |  |  |  |  |  |  |
| 142232250 | Signal Cable Procurement Prep - Labor |  | 14d | 2012-08-01 A | 2012-08-20 A | 142232200M FS+477d | 100% |  |  | SCIENTIST [40 h] | 2,824.4 | 2,824.4 |  |  |  |  | 0 | 2914.4 | ELOUADRHIRI L | 1 | 1 | H | LATIFA E | 10-017 | 11-021 | 11-026 |  | 11 -035 |  |  |  |  |  |  |  |  |  |  |  |  |  |
| 142232260 | High Voltage Cable Procurement Prep - Labor |  | 14d | 2012-08-01 A | 2012-08-20 A | 142232200M FS+477d | 100% |  |  | SCIENTIST [40 h] | 2,824.4 | 2,824.4 |  |  |  |  | 0 | 2914.4 | ELOUADRHIRI L | 1 | 1 | H | LATIFA E | 10-017 | 11-021 | 11-026 |  | 11 -035 |  |  |  |  |  |  |  |  |  |  |  |  |  |
| 142232290 | Support Frame Procurement Prep - Labor |  | 73d | 2012-08-01 A | 2012-11-12 A | 142232200M | 100% |  |  | SCIENTIST [80 h] | 5,725.24 | 5,725.24 |  |  |  |  | 0 | 5828.8 | ELOUADRHIRI L | 1 | 1 | H | LATIFA E | 10-017 | 11-021 | 11-026 |  | 11 -035 |  |  |  |  |  |  |  |  |  |  |  |  |  |
| 142232300 | Divider adaptor Procurement Prep - Labor |  | 14d | 2012-08-01 A | 2012-08-20 A | 142232200M FS+477d | 100% |  |  | SCIENTIST [40 h] | 2,824.4 | 2,824.4 |  |  |  |  | 0 | 2914.4 | ELOUADRHIRI L | 1 | 1 | H | LATIFA E | 10-017 | 11-021 | 11-026 |  | 11 -035 |  |  |  |  |  |  |  |  |  |  |  |  |  |
| 142232400 | Deinstallation S1 |  | 1d | 2012-08-04 A | 2012-08-06 A | 142232375M FS+108d, 142232354 | 100% | 2012-08-06 | 2012-08-06 |  |  |  |  |  |  |  |  | 0 | ELOUADRHIRI L | 1 | 1 | Z | LATIFA E | 10-017 | 11-021 | 11-026 | 11-032 | 11 -035 |  | 12-054F |  |  |  |  |  |  |  |  |  |  |  |
| 142232420 | Deinstallation S2 |  | 1d | 2012-08-04 A | 2012-08-06 A | 142232405 FS-3d | 100% | 2012-08-06 | 2012-08-06 |  |  |  |  |  |  |  |  | 0 | ELOUADRHIRI L | 1 | 1 | Z | LATIFA E | 10-017 | 11-021 | 11-026 | 11-032 | 11 -035 |  | 12-054F |  |  |  |  |  |  |  |  |  |  |  |
| 142232565 | Deinstallation |  | 104d | 2012-08-04 A | 2013-01-09 A | 142232505 | 100% | 2012-08-06 | 2013-01-09 |  |  |  |  |  |  |  |  | 0 | ELOUADRHIRI L | 1 | 1 | Z | LATIFA E | 10-017 | 11-021 | 11-026 | 11-032 | 11 -035 |  | 12-054F |  |  |  |  | XX |  |  |  |  |  |  |
| 142232440 | Deinstallation S3 |  | 1d | 2012-08-05 A | 2012-08-06 A | 142232425 FS-1d | 100% | 2012-08-06 | 2012-08-06 |  |  |  |  |  |  |  |  | 0 | ELOUADRHIRI L | 1 | 1 | Z | LATIFA E | 10-017 | 11-021 | 11-026 | 11-032 | 11 -035 |  | 12-054F |  |  |  |  |  |  |  |  |  |  |  |
| 142232460 | Deinstallation S4 |  | 1d | 2012-08-05 A | 2012-08-06 A | 142232445 FS-1d | 100% | 2012-08-06 | 2012-08-06 |  |  |  |  |  |  |  |  | 0 | ELOUADRHIRI L | 1 | 1 | Z | LATIFA E | 10-017 | 11-021 | 11-026 | 11-032 | 11 -035 |  | 12-054F |  |  |  |  |  |  |  |  |  |  |  |
| 142232405 | Move S1 to storage |  | 2d | 2012-08-06 A | 2012-08-07 A | 142232400, 142232375M FS+108d, 142232363 | 100% |  |  | PROCUREMENT<$50K 60 | 2,579.75 |  | 0 | 2579.75 | 257975 | 100 | 0 | 2579.75 | ELOUADRHIRI L | 1 | 1 | H | LATIFA E | 10-017 | 11-021 | 11-026 | 11-032 | 11 -035 |  | 12-054F |  |  |  |  |  |  |  |  |  |  |  |
| 142232425 | Move S2 to storage |  | 3d | 2012-08-06 A | 2012-08-08 A | 142232420 FS-2d | 100% |  |  |  |  |  |  |  |  |  |  | 0 | ELOUADRHIRI L | 1 | 1 | Z | LATIFA E | 10-017 | 11-021 | 11-026 | 11-032 | 11 -035 |  | 12-054F |  |  |  |  |  |  |  |  |  |  |  |
| 142232445 | Move S3 to storage |  | 3d | 2012-08-06 A | 2012-08-08 A | 142232440 FS-1d | 100% |  |  |  |  |  |  |  |  |  |  | 0 | ELOUADRHIRI L | 1 | 1 | Z | LATIFA E | 10-017 | 11-021 | 11-026 | 11-032 | 11 -035 |  | 12-054F |  |  |  |  |  |  |  |  |  |  |  |
| 142232465 | Move S4 to storage |  | 3d | 2012-08-06 A | 2012-08-08 A | 142232460 FS-2d | 100% |  |  |  |  |  |  |  |  |  |  | 0 | ELOUADRHIRI L | 1 | 1 | Z | LATIFA E | 10-017 | 11-021 | 11-026 | 11-032 | 11 -035 |  | 12-054F |  |  |  |  |  |  |  |  |  |  |  |
| 142232480 | Deinstallation S5 |  | 2d | 2012-08-06 A | 2012-08-07 A | 142232465 FS-1d | 100% |  |  |  |  |  |  |  |  |  |  | 0 | ELOUADRHIRI L | 1 | 1 | Z | LATIFA E | 10-017 | 11-021 | 11-026 | 11-032 | 11 -035 |  | 12-054F |  |  |  |  |  |  |  |  |  |  |  |
| 142232570 | Move Panel 2 to storage |  | 104d | 2012-08-06 A | 2013-01-15 A | 142232565 FS-25d | 100% | 2012-08-06 | 2013-01-09 | PROCUREMENT<$50K 60 | 2,579.75 |  | 0 | 2579.75 | 257975 | 100 | 0 | 2579.75 | ELOUADRHIRI L | 1 | 1 | H | LATIFA E | 10-017 | 11-021 | 11-026 | 11-032 | 11 -035 |  | 12-054F |  |  |  |  | XX |  |  |  |  |  |  |
| 142232485 | Move S5 to storage |  | 2d | 2012-08-07 A | 2012-08-08 A | 142232480 FS-1d | 100% |  |  |  |  |  |  |  |  |  |  | 0 | ELOUADRHIRI L | 1 | 1 | Z | LATIFA E | 10-017 | 11-021 | 11-026 | 11-032 | 11 -035 |  | 12-054F |  |  |  |  |  |  |  |  |  |  |  |
| 142232500 | Deinstallation S6 |  | 1d | 2012-08-07 A | 2012-08-07 A | 142232485 | 100% |  |  |  |  |  |  |  |  |  |  | 0 | ELOUADRHIRI L | 1 | 1 | Z | LATIFA E | 10-017 | 11-021 | 11-026 | 11-032 | 11 -035 |  | 12-054F |  |  |  |  |  |  |  |  |  |  |  |
| 142232505 | Move S6 to storage |  | 1d | 2012-08-10 A | 2012-08-10 A | 142232500 | 100% |  |  |  |  |  |  |  |  |  |  | 0 | ELOUADRHIRI L | 1 | 1 | Z | LATIFA E | 10-017 | 11-021 | 11-026 | 11-032 | 11 -035 |  | 12-054F |  |  |  |  |  |  |  |  |  |  |  |
| 142232510 | S6 Counter QA and baseline measurements |  | 11d | 2012-08-13 A | 2012-08-27 A | 142232495 FS-185d | 100% |  |  | MECH TECH [160 h] | 7,110.4 | 7,110.4 |  |  |  |  | 0 | 7337.6 | ELOUADRHIRI L | 1 | 1 | H | LATIFA E | 10-017 | 11-021 | 11-026 |  | 11 -035 | 12-007 |  |  |  |  |  |  |  |  |  |  |  |  |
| 142232410 | S1 Counter QA and baseline measurements |  | 6d | 2012-08-20 A | 2012-08-27 A | 142232375M FS+23d, 142232405 FS+13d | 100% |  |  | MECH TECH [160 h] | 7,110.4 | 7,110.4 |  |  |  |  | 0 | 7110.4 | ELOUADRHIRI L | 1 | 1 | H | LATIFA E | 10-017 | 11-021 | 11-026 |  | 11 -035 | 12-007 |  |  |  |  |  |  |  |  |  |  |  |  |
| 142232305 | Divider adaptor procurement |  | 69d | 2012-09-03 A | 2012-12-10 A | 142232300 | 100% | 2012-09-04 | 2012-12-11 | PROCUREMENT<$50K 60 | 43,951.41 |  | 0 | 43951.41 | 4395141 | 100 | 0 | 43951.41 | ELOUADRHIRI L | 1 | 1 | D | LATIFA E | 10-017 | 11-021 | 11-026 |  | 11 -035 |  |  |  |  |  |  |  |  |  |  |  |  |  |
| 142232415 | S1 repair |  | 50d | 2012-09-03 A | 2012-11-12 A | 142232410, 142232373 FS-20d | 100% | 2012-09-04 | 2012-11-12 | SCIENTIST [28.57 h]; MECH TECH [171.43 h] | 9,826.46 | 9,826.46 |  |  |  |  | 0 | 9943.39 | ELOUADRHIRI L | 1 | 1 | U | LATIFA E | 10-017 | 11-021 | 11-026 | 11-032 | 11 -035 | 12-007 |  |  |  |  |  |  |  |  |  |  |  |  |
| 142232575 | Extract panel-2 counters from CLAS6 FY12 |  | 84d | 2012-09-03 A | 2013-01-15 A | 142232570 FS-25d | 100% | 2012-09-04 | 2013-01-09 | MECH TECH [356.76 h] | 16,246.43 | 16,251.63 |  |  |  |  | 0 | 15854.4144 | ELOUADRHIRI L | 1 | 1 | U | LATIFA E | 10-017 | 11-021 | 11-026 | 11-032 | 11 -035 |  | 12-054F |  |  |  |  | XX |  | 12-053 |  |  |  |  |
| 142232575a | Extract panel-2 counters from CLAS6 FY13 |  | 84d | 2012-09-03 A | 2013-01-15 A | 142232575 FS-70d | 100% | 2012-09-04 | 2013-01-09 | MECH TECH [123.24 h] | 5,612.2 | 5,614 |  |  |  |  | 0 | 5651.7864 | ELOUADRHIRI L | 1 | 1 | U | LATIFA E | 10-017 | 11-021 | 11-026 | 11-032 | 11 -035 |  | 12-054F |  |  |  |  | XX |  | 12-053 |  |  |  |  |
| 142232232 | Forward carriage patch panels procurement |  | 74d | 2012-09-10 A | 2013-07-15 A | 142232231 | 100% | 2012-09-10 | 2012-12-31 | PROCUREMENT<$50K 60; PROCUREMENT>$50K 69 | 53,658.8 |  | 0 | 53658.8 | 5365880 | 100 | 12341.524 | 53658.8 | ELOUADRHIRI L | 1 | 1 | D | LATIFA E | 10-017 | 11-021 | 11-026 | 11-032 | 11 -035 | 12-007 |  | 11-001 | 11-056 |  |  | XX |  |  |  |  |  |  |
| 142232234 | Patch panel to electronics cables procurement |  | 46d | 2012-09-10 A | 2012-11-12 A | 142232233 | 100% |  |  | PROCUREMENT<$50K 60 | 23,011.37 |  | 0 | 23011.37 | 2301137 | 100 | 0 | 23011.37 | ELOUADRHIRI L | 1 | 1 | D | LATIFA E | 10-017 | 11-021 | 11-026 | 11-032 | 11 -035 | 12-007 |  | 11-001 | 11-056 |  |  |  |  |  |  |  |  |  |
| 142232255 | Signal Cable Procurement |  | 78d | 2012-09-10 A | 2012-12-17 A | 142232250 | 100% | 2012-09-10 | 2013-01-07 | PROCUREMENT<$50K 60 | 28,678.3 |  | 0 | 28678.3 | 2867830 | 100 | 0 | 28678.3 | ELOUADRHIRI L | 1 | 1 | D | LATIFA E | 10-017 | 11-021 | 11-026 |  | 11 -035 |  |  |  |  |  |  |  |  |  |  |  |  |  |
| 142232265 | High Voltage Cable Procurement |  | 78d | 2012-09-10 A | 2013-08-30 A | 142232260 | 100% | 2012-09-10 | 2013-01-07 | PROCUREMENT<$50K 60 | 53,400.97 |  | 0 | 53400.97 | 5340097 | 100 | 11748.2134 | 53400.97 | ELOUADRHIRI L | 1 | 1 | D | LATIFA E | 10-017 | 11-021 | 11-026 |  | 11 -035 |  |  |  |  |  |  | XX |  |  |  |  |  |  |
| 142232515 | S6 repair |  | 257d | 2012-09-10 A | 2013-03-15 A | 142232510 | 100% | 2012-09-10 | 2013-09-20 | SCIENTIST [28.57 h]; MECH TECH [171.43 h] | 9,925.43 | 9,906.16 |  |  |  |  | 0 | 2983.017 | ELOUADRHIRI L | 1 | 1 | U | LATIFA E | 10-017 | 11-021 | 11-026 | 11-032 | 11 -035 | 12-007 |  |  |  |  |  |  |  |  |  |  |  |  |
| 142232660 | Panel 1-a and Panel 2 signal cables and connectors (672) - proc |  | 83d | 2012-09-10 A | 2012-12-17 A | 142232650 FS-500d | 100% | 2012-09-10 | 2013-01-14 | PROCUREMENT<$50K 60 |  |  |  |  |  |  | 0 | 0 | ELOUADRHIRI L | 1 | 1 | D | LATIFA E | 10-017 | 11-021 | 11-026 | 11-032 | 11 -035 |  | 12-054 |  |  |  |  |  |  |  |  |  |  |  |
| 142232180 | FTOF Travel FY13 |  | 248d | 2012-10-01 A | 2013-08-30 A | 142232175 | 100% | 2012-10-01 | 2013-09-30 | TRAVEL | 6,977.53 |  |  |  |  |  | 1285.676546 | 6977.53 | ELOUADRHIRI L | 1 | 1 | E | LATIFA E | 10-017 | 11-021 | 11-026 | 11-032 | 11 -035 |  |  |  |  |  |  |  |  |  | 8.06451612 | 91.93548387 | 100 | 100 |
| 142232320H | Peg Point #6C - Phase 2 assembly start (next 42 units) Part 3 |  | 75d | 2012-10-08 A | 2013-01-31 A | 142232320G FS-57d | 100% |  |  | PROCUREMENT>$50K 69 NO ESCALATION; PROCUREMENT<$50K 60 NO ESCALATION | 68,244.69 |  | 0 | 68244.69 | 6824469 | 100 | 0 | 68244.69 | ELOUADRHIRI L | 1 | 1 | D | LATIFA E | 10-017 | 11-021 | 11-026 |  | 11 -035 |  |  |  |  |  |  | XX |  |  |  |  |  |  |
| 142232320J | Peg Point #7 - Phase 3 assembly start (last 17 units) |  | 179d | 2012-10-08 A | 2013-03-11 A | 142232320H FS-57d | 100% | 2012-10-08 | 2013-06-28 | PROCUREMENT>$50K 69 NO ESCALATION | 38,679.95 |  | 0 | 38679.95 | 3867995 | 100 | 0 | 38679.95 | ELOUADRHIRI L | 1 | 1 | D | LATIFA E | 10-017 | 11-021 | 11-026 |  | 11 -035 |  |  |  |  |  |  |  |  |  |  |  |  |  |
| 142232320K | Peg Point #8 - JLab Acceptance Test preparation start |  | 179d | 2012-10-08 A | 2013-07-15 A | 142232307 FS-20d, 142232320J FS-161d | 100% | 2012-10-08 | 2013-06-28 | PROCUREMENT>$50K 69 NO ESCALATION | 14,239.81 |  | 0 | 14239.81 | 1423981 | 100 | 14239.81 | 14239.81 | ELOUADRHIRI L | 1 | 1 | D | LATIFA E | 10-017 | 11-021 | 11-026 |  | 11 -035 |  |  |  |  |  |  |  |  |  |  |  |  |  |
| 142232320N | Peg Point #9 - Panel-1b counters delivered to JLab |  | 179d | 2012-10-08 A | 2013-07-15 A | 142232320K FS-161d | 100% | 2012-10-08 | 2013-06-28 | PROCUREMENT>$50K 69 NO ESCALATION | 28,702.47 |  | 0 | 28702.47 | 2870247 | 100 | 28702.47 | 28702.47 | ELOUADRHIRI L | 1 | 1 | D | LATIFA E | 10-017 | 11-021 | 11-026 |  | 11 -035 |  |  |  |  |  |  |  |  |  |  |  |  |  |
| 142232320P | Peg Point #10 - Sector assembly start |  | 223d | 2012-10-08 A | 2013-07-15 A | 142232320N FS-161d | 100% | 2012-10-08 | 2013-08-30 | PROCUREMENT>$50K 69 NO ESCALATION | 37,107.77 |  | 0 | 37107.77 | 3710777 | 100 | 37107.77 | 37107.77 | ELOUADRHIRI L | 1 | 1 | D | LATIFA E | 10-017 | 11-021 | 11-026 |  | 11 -035 |  |  |  |  |  |  |  |  |  |  |  |  |  |
| 142232490 | S5 Counter QA and baseline measurements |  | 175d | 2012-10-08 A | 2013-05-13 A | 142232475 FS-150d | 100% | 2012-10-08 | 2013-06-24 | MECH TECH [160 h] | 7,337.6 | 7,337.6 |  |  |  |  | 0 | 7337.6 | ELOUADRHIRI L | 1 | 1 | H | LATIFA E | 10-017 | 11-021 | 11-026 |  | 11 -035 | 12-007 |  |  |  |  |  |  |  |  |  |  |  |  |
| 142232495 | S5 repair |  | 196d | 2012-10-08 A | 2013-03-15 A | 142232490 FS-170d | 100% | 2012-10-08 | 2013-07-24 | SCIENTIST [28.57 h]; MECH TECH [171.43 h] | 9,943.39 | 9,943.39 |  |  |  |  | 0 | 9943.39 | ELOUADRHIRI L | 1 | 1 | U | LATIFA E | 10-017 | 11-021 | 11-026 | 11-032 | 11 -035 | 12-007 |  |  |  |  |  |  |  |  |  |  |  |  |
| 142232560 | Misc. Repair Parts |  | 227d | 2012-11-05 A | 2013-08-30 A | 142232200M FS+412d | 100% | 2012-11-05 | 2013-10-04 | PROCUREMENT<$50K 60 NO ESCALATION FY13 | 10,648.18 |  | 0 | 10648.18 | 1064818 | 100 | 10648.18 | 10648.18 | ELOUADRHIRI L | 1 | 1 | D | LATIFA E | 10-017 | 11-021 | 11-026 |  | 11 -035 |  |  |  |  |  |  |  |  |  |  |  |  |  |
| 142232430 | S2 Counter QA and baseline measurements |  | 6d | 2012-11-12 A | 2012-11-19 A | 142232425, 142232415 FS-50d | 100% |  |  | MECH TECH [160 h] | 7,337.6 | 7,337.6 |  |  |  |  | 0 | 7337.6 | ELOUADRHIRI L | 1 | 1 | H | LATIFA E | 10-017 | 11-021 | 11-026 |  | 11 -035 | 12-007 |  |  |  |  |  |  |  |  |  |  |  |  |
| 142232435 | S2 repair |  | 6d | 2012-11-12 A | 2012-11-19 A | 142232430 FS-60d | 100% |  |  | SCIENTIST [28.57 h]; MECH TECH [171.43 h] | 9,943.39 | 9,943.39 |  |  |  |  | 0 | 9943.39 | ELOUADRHIRI L | 1 | 1 | U | LATIFA E | 10-017 | 11-021 | 11-026 | 11-032 | 11 -035 | 12-007 |  |  |  |  |  |  |  |  |  |  |  |  |
| 142232450 | S3 Counter QA and baseline measurements |  | 6d | 2012-11-12 A | 2012-11-19 A | 142232435 FS-40d | 100% |  |  | MECH TECH [160 h] | 7,337.6 | 7,337.6 |  |  |  |  | 0 | 7337.6 | ELOUADRHIRI L | 1 | 1 | H | LATIFA E | 10-017 | 11-021 | 11-026 |  | 11 -035 | 12-007 |  |  |  |  |  |  |  |  |  |  |  |  |
| 142232455 | S3 repair |  | 6d | 2012-11-12 A | 2012-11-19 A | 142232450 FS-60d | 100% |  |  | SCIENTIST [28.57 h]; MECH TECH [171.43 h] | 9,943.39 | 9,943.39 |  |  |  |  | 0 | 9943.39 | ELOUADRHIRI L | 1 | 1 | U | LATIFA E | 10-017 | 11-021 | 11-026 | 11-032 | 11 -035 | 12-007 |  |  |  |  |  |  |  |  |  |  |  |  |
| 142232470 | S4 Counter QA and baseline measurements |  | 109d | 2012-11-12 A | 2013-04-15 A | 142232455 FS-90d | 100% | 2012-11-12 | 2013-04-25 | MECH TECH [160 h] | 7,337.6 | 7,337.6 |  |  |  |  | 0 | 7337.6 | ELOUADRHIRI L | 1 | 1 | H | LATIFA E | 10-017 | 11-021 | 11-026 |  | 11 -035 | 12-007 |  |  |  |  |  |  |  |  |  |  |  |  |
| 142232475 | S4 repair |  | 129d | 2012-11-12 A | 2013-03-14 A | 142232470 FS-110d | 100% | 2012-11-12 | 2013-05-23 | SCIENTIST [28.57 h]; MECH TECH [171.43 h] | 9,943.39 | 9,943.39 |  |  |  |  | 0 | 9943.39 | ELOUADRHIRI L | 1 | 1 | U | LATIFA E | 10-017 | 11-021 | 11-026 | 11-032 | 11 -035 | 12-007 |  |  |  |  |  |  |  |  |  |  |  |  |
| 142232680 | Panel 1-a and panel 2 HV cable testing |  | 10d | 2012-12-03 A | 2013-03-11 A |  | 100% | 2014-03-31 | 2014-04-11 | ELEC TECH |  |  |  |  |  |  | 0 | 0 | ELOUADRHIRI L | 1 | 1 | D | LATIFA E | 10-017 | 11-021 | 11-026 | 11-032 | 11 -035 |  | 12-054 |  |  |  |  |  |  |  |  |  |  |  |
| 142232525 | Install Frame Support Pieces |  | 29d | 2012-12-10 A | 2013-08-26 A | 142232520 | 100% | 2013-02-19 | 2013-03-29 | MECH TECH [80 h] | 3,668.8 | 3,668.8 |  |  |  |  | 623.696 | 3668.8 | ELOUADRHIRI L | 1 | 1 | U | LATIFA E | 10-017 | 11-021 | 11-026 |  | 11 -035 |  |  |  |  |  |  | XX |  |  |  |  |  |  |
| 142232585 | Counter QA and baseline measurements |  | 52d | 2013-01-09 A | 2013-05-13 A | 142232575a, 142232580a FS-47d | 100% | 2013-02-15 | 2013-05-01 | MECH TECH [240 h] | 11,006.4 | 11,006.4 |  |  |  |  | 0 | 11006.4 | ELOUADRHIRI L | 1 | 1 | H | LATIFA E | 10-017 | 11-021 | 11-026 | 11-032 | 11 -035 |  | 12-054 |  |  |  |  |  |  | 12-053 |  |  |  |  |
| 142232295 | Support Frame Procurement |  | 84d | 2013-01-16 A | 2013-04-29 A | 142232290, 142232350 | 100% | 2013-01-16 | 2013-05-15 | PROCUREMENT<$50K 60 | 35,161.13 |  | 0 | 35161.13 | 3516113 | 100 | 0 | 35161.13 | ELOUADRHIRI L | 1 | 1 | D | LATIFA E | 10-017 | 11-021 | 11-026 |  | 11 -035 |  |  |  |  |  |  |  |  |  |  |  |  |  |
| 142232590 | Counter repair |  | 120d | 2013-01-31 A | 2013-03-11 A | 142232585 FS-50d | 100% | 2013-05-01 | 2013-10-21 | MECH TECH [960 h] | 44,190.58 | 44,025.6 |  |  |  |  | 0 | 40751.196 | ELOUADRHIRI L | 1 | 1 | H | LATIFA E | 10-017 | 11-021 | 11-026 | 11-032 | 11 -035 | 12-007 | 12-054 |  |  |  |  |  |  |  |  |  |  |  |
| 142232580 | Set up FTOF DAQ + Test Station FY12 |  | 17d | 2013-02-11 A | 2013-04-15 A | 142232395 | 100% | 2013-03-22 | 2013-04-15 | SCIENTIST [62.46 h] | 4,550.84 | 4,550.84 |  |  |  |  | 0 | 4410.3006 | ELOUADRHIRI L | 1 | 1 | H | LATIFA E | 10-017 | 11-021 | 11-026 | 11-032 | 11 -035 |  | 12-054F |  |  | 12-018F | 13-006F |  |  | 12-053 |  |  |  |  |
| 142232580a | Set up FTOF DAQ + Test Station FY13 |  | 17.12d | 2013-02-11 A | 2013-04-15 A | 142232580 FS-30d | 100% | 2013-03-22 | 2013-04-16 | SCIENTIST [17.54 h] | 1,277.96 | 1,277.96 |  |  |  |  | 0 | 1277.9644 | ELOUADRHIRI L | 1 | 1 | H | LATIFA E | 10-017 | 11-021 | 11-026 | 11-032 | 11 -035 |  | 12-054F |  |  | 12-018F | 13-006F |  |  | 12-053 |  |  |  |  |
| 142232535 | Set up FTOF DAQ + Test Station |  | 59d | 2013-03-04 A | 2013-08-30 A | 142232530 FS-63d | 100% | 2013-04-30 | 2013-07-23 | SCIENTIST [40 h] | 2,914.4 | 2,914.4 |  |  |  |  | 1457.2 | 2914.4 | ELOUADRHIRI L | 1 | 1 | H | LATIFA E | 10-017 | 11-021 | 11-026 |  | 11 -035 |  |  |  |  |  |  |  |  |  |  |  |  |  |

Notes:
- 142232565: Constraints and Assumptions: Comes from Doug Tilles CLAS6 Deinstallation / Schedule.

| ID | Activity | Type | Duration | Start | Finish | Predecessors | Complete | Remaining | Planned start | Planned finish | Total float | Free float | Calendar | Resources | Cost | Actual cost | Calculated Remaining Total Cost | MONTHLY EV COST | RESP - Responsibility | STRT%COMP for CM EVM | FNSH%COMP for CM EVM | EVMS Reporting Codes | CAM RESPONSIBLE | CR 10-017 | CR 11-021 | CR 11-026 | CR 11-032 | CR 11-035 | CR 12-007 | CR 12-054 | Claimed Material Divider | ReBaseline Actuals Adjustment | LOE Divider | LOE Multiplier | Original Activity ID Rebaseline | PRIOR MONTH EV COST | CR 13-002 | BOE Expenses | CR 13-015 | Post Rebaseline | Remaining Material Cost Based on % Compl | Claimed Material Cost Based on % Complet | Initial Claimed Material Calc | CR 11-001 | CR 11-056 | BOE Procurement | Obligated Prior to Rebaseline | CR 14-001 | BOE Labor | LOE % Pre Calc | LOE % | Activities with Steps | CR 13-010 |
| --- | --- | --- | --- | --- | --- | --- | --- | --- | --- | --- | --- | --- | --- | --- | --- | --- | --- | --- | --- | --- | --- | --- | --- | --- | --- | --- | --- | --- | --- | --- | --- | --- | --- | --- | --- | --- | --- | --- | --- | --- | --- | --- | --- | --- | --- | --- | --- | --- | --- | --- | --- | --- | --- |
| 142232595 | Mount S1 counters to frame |  | 10d | 2013-03-11 A | 2013-03-15 A | 142232590 FS-33d | 100% |  | 2013-08-08 | 2013-08-21 |  |  |  | MECH TECH [80 h] | 3,668.8 | 3,668.8 | 0 | 3668.8 | ELOUADRHIRI L | 1 | 1 | H | LATIFA E | 10-017 | 11-021 | 11-026 | 11-032 | 11 -035 | 12-007 | 12-054 |  |  |  |  |  |  |  |  |  |  |  |  |  |  |  |  |  |  |  |  |  |  |  |
| 142232605 | Mount S2 counters to frames |  | 10d | 2013-03-11 A | 2013-03-18 A | 142232600 FS-20d | 100% |  | 2013-08-29 | 2013-09-12 |  |  |  | MECH TECH [72 h] | 3,301.92 | 3,301.92 | 0 | 3301.92 | ELOUADRHIRI L | 1 | 1 | H | LATIFA E | 10-017 | 11-021 | 11-026 | 11-032 | 11 -035 | 12-007 | 12-054 |  |  |  |  |  |  |  |  |  |  |  |  |  |  |  |  |  |  |  |  |  |  |  |
| 142232615 | Mount S3 counters to frames |  | 9d | 2013-03-11 A | 2013-03-18 A | 142232610 FS-20d | 100% |  | 2013-09-20 | 2013-10-02 |  |  |  | MECH TECH |  |  | 0 | 0 | ELOUADRHIRI L | 1 | 1 | H | LATIFA E | 10-017 | 11-021 | 11-026 | 11-032 | 11 -035 | 12-007 | 12-054 |  |  |  |  |  |  |  |  |  |  |  |  |  |  |  |  |  |  |  |  |  |  |  |
| 142232625 | Mount S4 counters to frames |  | 10d | 2013-03-11 A | 2013-03-18 A | 142232620 FS-20d | 100% |  | 2013-10-10 | 2013-10-23 |  |  |  | MECH TECH |  |  | 0 | 0 | ELOUADRHIRI L | 1 | 1 | H | LATIFA E | 10-017 | 11-021 | 11-026 | 11-032 | 11 -035 | 12-007 | 12-054 |  |  |  |  |  |  |  |  |  |  |  |  |  |  |  |  |  |  |  |  |  |  |  |
| 142232635 | Mount S5 counters to frames |  | 10d | 2013-03-11 A | 2013-03-15 A | 142232630 FS-20d | 100% |  | 2013-10-30 | 2013-11-12 |  |  |  | MECH TECH |  |  | 0 | 0 | ELOUADRHIRI L | 1 | 1 | H | LATIFA E | 10-017 | 11-021 | 11-026 | 11-032 | 11 -035 | 12-007 | 12-054 |  |  |  |  |  |  |  |  |  |  |  |  |  |  |  |  |  |  |  |  |  |  |  |
| 142232645 | Mount S6 counters to frames |  | 10d | 2013-03-11 A | 2013-03-15 A | 142232640 FS-20d | 100% |  | 2013-11-20 | 2013-12-05 |  |  |  | MECH TECH |  |  | 0 | 0 | ELOUADRHIRI L | 1 | 1 | H | LATIFA E | 10-017 | 11-021 | 11-026 | 11-032 | 11 -035 | 12-007 | 12-054 |  |  |  |  |  |  |  |  |  |  |  |  |  |  |  |  |  |  |  |  |  |  |  |
| 142232665 | Panel 1-a and Panel 2 signal cables and connectors (672) - assy&test |  | 15d | 2013-03-11 A | 2013-03-25 A | 142232660 FS+263d | 100% |  | 2014-01-16 | 2014-02-06 |  |  |  | ELEC TECH |  |  | 0 | 0 | ELOUADRHIRI L | 1 | 1 | D | LATIFA E | 10-017 | 11-021 | 11-026 | 11-032 | 11 -035 |  | 12-054 |  |  |  |  |  |  |  |  |  |  |  |  |  |  |  |  |  |  |  |  |  |  |  |
| 142232600 | S1 panel-2 QA |  | 5d | 2013-04-01 A | 2013-05-13 A | 142232595 | 100% |  | 2013-05-01 | 2013-05-07 |  |  |  | MECH TECH [40 h] | 1,834.4 | 1,834.4 | 0 | 1834.4 | ELOUADRHIRI L | 1 | 1 | H | LATIFA E | 10-017 | 11-021 | 11-026 | 11-032 | 11 -035 | 12-007 | 12-054 |  |  |  |  |  |  |  |  |  |  |  |  |  |  |  |  |  |  |  |  |  |  |  |
| 142232610 | S2 panel-2 QA |  | 5d | 2013-04-01 A | 2013-05-13 A | 142232605 FS-10d | 100% |  | 2013-05-08 | 2013-05-14 |  |  |  | MECH TECH |  |  | 0 | 0 | ELOUADRHIRI L | 1 | 1 | H | LATIFA E | 10-017 | 11-021 | 11-026 | 11-032 | 11 -035 | 12-007 | 12-054 |  |  |  |  |  |  |  |  |  |  |  |  |  |  |  |  |  |  |  |  |  |  |  |
| 142232620 | S3 panel-2 QA |  | 5d | 2013-04-01 A | 2013-05-13 A | 142232615 FS-10d | 100% |  | 2013-05-15 | 2013-05-21 |  |  |  | MECH TECH |  |  | 0 | 0 | ELOUADRHIRI L | 1 | 1 | H | LATIFA E | 10-017 | 11-021 | 11-026 | 11-032 | 11 -035 | 12-007 | 12-054 |  |  |  |  |  |  |  |  |  |  |  |  |  |  |  |  |  |  |  |  |  |  |  |
| 142232630 | S4 panel-2 QA |  | 4d | 2013-04-01 A | 2013-05-13 A | 142232625 FS-20d | 100% |  | 2013-05-22 | 2013-05-28 |  |  |  | MECH TECH |  |  | 0 | 0 | ELOUADRHIRI L | 1 | 1 | H | LATIFA E | 10-017 | 11-021 | 11-026 | 11-032 | 11 -035 | 12-007 | 12-054 |  |  |  |  |  |  |  |  |  |  |  |  |  |  |  |  |  |  |  |  |  |  |  |
| 142232640 | S5 panel-2 QA |  | 5d | 2013-04-01 A | 2013-05-13 A | 142232635 FS-20d | 100% |  | 2013-05-29 | 2013-06-04 |  |  |  | MECH TECH |  |  | 0 | 0 | ELOUADRHIRI L | 1 | 1 | H | LATIFA E | 10-017 | 11-021 | 11-026 | 11-032 | 11 -035 | 12-007 | 12-054 |  |  |  |  |  |  |  |  |  |  |  |  |  |  |  |  |  |  |  |  |  |  |  |
| 142232650 | S6 panel-2 QA |  | 5d | 2013-04-01 A | 2013-05-13 A | 142232645 FS-30d | 100% |  | 2013-06-05 | 2013-06-11 |  |  |  | MECH TECH |  |  | 0 | 0 | ELOUADRHIRI L | 1 | 1 | H | LATIFA E | 10-017 | 11-021 | 11-026 | 11-032 | 11 -035 | 12-007 | 12-054 |  |  |  |  |  |  |  |  |  |  |  |  |  |  |  |  |  |  |  |  |  |  |  |
| 142232530 | Prepare JLAB construction space |  | 33d | 2013-05-06 A | 2013-06-17 A | 142232320N FS-50d | 100% |  | 2013-06-13 | 2013-07-30 |  |  |  | MECH TECH [40 h] | 1,834.4 | 1,834.4 | 0 | 1834.4 | ELOUADRHIRI L | 1 | 1 | H | LATIFA E | 10-017 | 11-021 | 11-026 |  | 11 -035 |  |  |  |  |  |  |  |  |  |  |  |  |  |  |  |  |  |  |  |  |  |  |  |  |  |
| 142232540 | Unload counters |  | 4d | 2013-06-10 A | 2013-06-17 A | 142232535 FS-60d | 100% |  | 2013-07-23 | 2013-07-26 |  |  |  | MECH TECH [40 h] | 1,834.4 | 1,834.4 | 0 | 1834.4 | ELOUADRHIRI L | 1 | 1 | H | LATIFA E | 10-017 | 11-021 | 11-026 | 11-032 | 11 -035 |  |  |  |  |  |  |  |  |  |  |  |  |  |  |  |  |  |  |  |  |  |  |  |  |  |
| 142232545 | Mount counters to support frame |  | 87d | 2013-06-10 A | 2013-08-26 A | 142232540 FS-40d | 100% |  | 2013-08-26 | 2014-01-06 |  |  |  | MECH TECH [160 h] | 7,504.07 | 7,337.6 | 3668.8 | 2108.6428 | ELOUADRHIRI L | 1 | 1 | H | LATIFA E | 10-017 | 11-021 | 11-026 |  | 11 -035 |  |  |  |  |  |  |  |  |  |  |  |  |  |  |  |  |  |  |  |  |  |  |  |  |  |
| 142232546 | Panel 1-b QA and baseline measurements |  | 101d | 2013-08-30 A | 2013-08-30 A | 142232545 FS-84d | 100% |  | 2013-09-03 | 2014-02-03 |  |  |  | MECH TECH [720 h] | 33,862.24 | 33,019.2 | 33019.2 | 7192.2238 | ELOUADRHIRI L | 1 | 1 | H | LATIFA E | 10-017 | 11-021 | 11-026 | 11-032 | 11 -035 | 12-007 |  |  |  |  |  |  |  |  |  |  |  |  |  |  |  |  |  |  |  |  |  |  |  |  |
| 142232690 | Re-Baseline Actuals Adjustment |  | 1d | 2013-08-30 A | 2013-08-30 A |  | 100% |  | 2013-09-03 | 2013-09-03 |  |  |  | PROCUREMENT>$50K 69 NO ESCALATION | -159,761.25 |  |  |  |  |  |  |  |  |  |  |  |  |  |  |  | 100 | ADJ |  |  |  |  |  |  |  |  |  |  |  |  |  |  |  |  |  |  |  |  |  |
| 242232180 | FTOF Travel FY13 |  | 20d | 2013-09-03 A | 2013-09-30 A | 9-130M FS+228d | 100% |  | 2013-10-01 | 2013-10-28 |  |  | 8/5 M-F w/JLAB Holidays ReBaseline | TRAVEL | 611.93 |  |  | 0 | ELOUADRHIRI L | 1 | 1 | E | LATIFA E | 10-017 | 11-021 | 11-026 | 11-032 | 11 -035 |  |  |  |  | 100 | 100 | 242232180 | 611.93 | 13-002F | PE | 13-015 | PR |  |  |  |  |  |  |  |  |  |  |  |  |  |
| 242232232 | Forward carriage patch panels procurement |  | 77d | 2013-09-03 A | 2014-02-28 | 9-140M | 41% | 75d | 2013-10-30 | 2014-02-28 | 453d | 43d | 8/5 M-F w/JLAB Holidays ReBaseline | PROCUREMENT<$50K 60; PROCUREMENT>$50K 69 | 5,475.26 |  |  | 0 | ELOUADRHIRI L | 1 | 1 | D | LATIFA E | 10-017 | 11-021 | 11-026 | 11-032 | 11 -035 | 12-007 |  | 100 |  |  |  | 242232232 | 2244.8566 | 13-002F |  | 13-015 | PR | 3230.4034 | 2244.8566 | 224485.66 | 11-001 | 11-056 | EJ | OB-2 | 14-001 |  |  |  |  |  |
| 242232265a | High Voltage Cable Procurement (Patch Panel Plates/Brackets) |  | 77d | 2013-09-03 A | 2013-09-23 A | 9-140M FS+21d | 100% |  | 2013-10-30 | 2014-02-28 |  |  | 8/5 M-F w/JLAB Holidays ReBaseline | PROCUREMENT<$50K 60 | 8,081.02 |  |  | 0 | ELOUADRHIRI L | 1 | 1 | D | LATIFA E | 10-017 | 11-021 | 11-026 |  | 11 -035 |  |  | 100 |  |  |  | 242232265a | 8081.02 | 13-002F |  | 13-015 | PR | 0 | 8081.02 | 808102 |  |  | EJ | OB-2 | 14-001 |  |  |  |  |  |
| 242232320Q | Peg Point #11 - Counter baseline measurements complete |  | 77d | 2013-09-03 A | 2014-03-31 | 9-130M FS+228d | 64% | 96d | 2013-10-01 | 2014-01-30 | 398d | 4d | 8/5 M-F w/JLAB Holidays ReBaseline | PROCUREMENT>$50K 69 NO ESCALATION | 53,642.72 |  |  | 10192.1168 | ELOUADRHIRI L | 1 | 1 | D | LATIFA E | 10-017 | 11-021 | 11-026 |  | 11 -035 |  |  | 100 |  |  |  | 242232320Q | 24139.224 | 13-002F |  | 13-015 | PR | 19311.3792 | 34331.3408 | 3433134.08 |  |  | OB | OB |  |  |  |  |  |  |
| 242232320R | Peg Point #12 - Panel-1b assembly and testing complete |  | 77d | 2013-09-03 A | 2014-03-31 | 242232320Q FS-100d |  | 96d | 2013-10-01 | 2014-01-30 | 394d | 0d | 8/5 M-F w/JLAB Holidays ReBaseline | PROCUREMENT>$50K 69 NO ESCALATION | 121,530.65 |  |  | 0 | ELOUADRHIRI L | 1 | 1 | D | LATIFA E | 10-017 | 11-021 | 11-026 |  | 11 -035 |  |  | 100 |  |  |  | 242232320R |  | 13-002F |  | 13-015 | PR | 121530.65 | 0 | 0 |  |  | OB | OB |  |  |  |  |  |  |
| 242232546 | Panel 1-b QA and baseline measurements FY13 |  | 20d | 2013-09-03 A | 2014-02-28 | 9-130M FS+228d |  | 75d | 2013-10-01 | 2013-10-28 | 453d | 43d | 8/5 M-F w/JLAB Holidays ReBaseline | MECH TECH [27.12 h]; CONTRB UNIV LBR [433.9 h] | 1,283.26 | 460.92 |  | 0 | ELOUADRHIRI L | 1 | 1 | U | LATIFA E | 10-017 | 11-021 | 11-026 | 11-032 | 11 -035 | 12-007 |  |  |  |  |  | 242232546 |  | 13-002F |  | 13-015 | PR |  |  |  |  |  |  |  |  | PE |  |  |  |  |
| 242232546a | Panel 1-b QA and baseline measurements FY14 |  | 98d | 2013-09-03 A | 2014-02-28 | 242232546 FS-130d |  | 75d | 2013-10-29 | 2014-03-28 | 453d | 43d | 8/5 M-F w/JLAB Holidays ReBaseline | MECH TECH [132.88 h]; CONTRB UNIV LBR [2126.1 h] | 6,287.94 | 2,258.48 |  | 0 | ELOUADRHIRI L | 1 | 1 | U | LATIFA E | 10-017 | 11-021 | 11-026 | 11-032 | 11 -035 | 12-007 |  |  |  |  |  | 242232546 |  | 13-002F |  | 13-015 | PR |  |  |  |  |  |  |  | 14-001 | PE |  |  |  |  |
| 242232185 | FTOF Travel FY14 |  | 57d | 2013-10-01 A | 2013-12-20 | 242232180 | 40% | 34d | 2013-11-01 | 2014-02-04 | 494d | 84d | 8/5 M-F w/JLAB Holidays ReBaseline | TRAVEL | 2,267.68 |  |  | 915.00888 | ELOUADRHIRI L | 1 | 1 | E | LATIFA E | 10-017 | 11-021 | 11-026 |  | 11 -035 |  |  |  |  | 100 | 100 | 242232185 |  | 13-002F | PE | 13-015 | PR |  |  |  |  |  |  |  | 14-001 |  | 59.6491228 | 40.35087719 |  |  |
| 242232320S | De-Obligation of USC Contract |  | 1d | 2013-10-01 A | 2014-03-31 | 242232320R FS-96d | 21% | 96d | 2014-03-31 | 2014-03-31 | 394d | 0d | 8/5 M-F w/JLAB Holidays ReBaseline | PROCUREMENT>$50K 69 NO ESCALATION | -46,530.65 |  |  | 0 | ELOUADRHIRI L | 1 | 1 | D | LATIFA E | 10-017 | 11-021 | 11-026 |  | 11 -035 |  |  | 100 |  |  |  | 242232320R |  | 13-002F |  | 13-015 | PR | -36531.213315 | -9999.436685 | -999943.6685 |  |  | OB | OB-2 |  |  |  |  | NB |  |
| 242232560 | Misc. Repair Parts |  | 77d | 2013-11-01 | 2014-03-04 | 9-140M FS+16d |  |  |  |  | 451d | 41d | 8/5 M-F w/JLAB Holidays ReBaseline | SUPPLIES & MATERIALS | 5,493.93 |  |  | 0 | ELOUADRHIRI L | 1 | 1 | D | LATIFA E | 10-017 | 11-021 | 11-026 |  | 11 -035 |  |  |  |  |  |  | 242232560 |  | 13-002F | PE | 13-015 | PR |  |  |  |  |  |  |  | 14-001 |  |  |  |  |  |
| 242232655 | Panel 2 Support Frame Procurement |  | 139d | 2013-11-01 | 2014-05-30 | 9-140M FS+20d, 9-130M FS+245d |  |  |  |  | 410d | 0d | 8/5 M-F w/JLAB Holidays ReBaseline | PROCUREMENT<$50K 60 NO ESCALATION FY14 | 4,471.68 |  |  | 0 | ELOUADRHIRI L | 1 | 1 | D | LATIFA E | 10-017 | 11-021 | 11-026 | 11-032 | 11 -035 |  |  | 100 |  |  |  | 242232655 |  | 13-002F |  | 13-015 | PR | 4471.68 | 0 | 0 |  |  | EJ |  |  |  |  |  |  |  |
| 242232396 | Calibration test equipment Procurement |  | 77d | 2013-12-05 | 2014-04-03 | 9-140M FS+45d |  |  |  |  | 429d | 19d | 8/5 M-F w/JLAB Holidays ReBaseline | PROCUREMENT<$50K 60 | 2,663.97 |  |  | 0 | ELOUADRHIRI L | 1 | 1 | D | LATIFA E | 10-017 | 11-021 | 11-026 | 11-032 | 11 -035 | 12-007 |  | 100 |  |  |  | 242232396 |  | 13-002F |  | 13-015 | PR | 2663.97 | 0 | 0 |  | 11-056 | PE |  | 14-001 |  |  |  |  |  |
| 242232685M | FTOF Complete | milestone | 0d | 2014-05-01 | 2014-05-01 | 242232232, 242232560, 242232655 FS-21d, 242232185, 242232320R, 242232396, 242232546a, 242232546, 242232265a, 242232320S |  |  |  |  | 410d | 503d | 8/5 M-F w/JLAB Holidays ReBaseline |  |  |  |  | 0 | ELOUADRHIRI L | 1 | 1 | M | LATIFA E | 10-017 | 11-021 | 11-026 | 11-032 | 11 -035 |  | 12-054 |  |  |  |  | 242232685M |  | 13-002F |  | 13-015 | PR |  |  |  |  |  |  |  |  |  |  |  |  | 13-010 |

Notes:
- 242232320S: Explanation: EVMS Code of D ....Partially / deobligated in October with more to follow per Latifa. PMK 11/7/13

| ID | WBS | Activity | Type | Duration | Start | Finish | Predecessors | Complete | Planned start | Planned finish | Resources | Cost | Actual cost | MONTHLY EV COST | RESP - Responsibility | STRT%COMP for CM EVM | FNSH%COMP for CM EVM | Milestone Level | EVMS Reporting Codes | CAM RESPONSIBLE | CR 08-052 | CR 11-026 | CR 11-035 | CR 12-007 | Calculated Remaining Total Cost | CR 10-001 | Advance Purchase Plan > 500K | CR 10-016 | Activities with Steps | Remaining Material Cost Based on % Compl | Claimed Material Cost Based on % Complet | Initial Claimed Material Calc | Claimed Material Divider | CR 10-060 | CR 11-001 | CR 12-054 | CR 12-001 | MARCH!!! | CR 12-055 | CR 12-053 |
| --- | --- | --- | --- | --- | --- | --- | --- | --- | --- | --- | --- | --- | --- | --- | --- | --- | --- | --- | --- | --- | --- | --- | --- | --- | --- | --- | --- | --- | --- | --- | --- | --- | --- | --- | --- | --- | --- | --- | --- | --- |
|  | 4 | **1.4.2.2.4 CERENKOV** |  |  | 2009-08-10 | 2015-06-19 |  |  |  |  |  |  |  |  |  |  |  |  |  |  |  |  |  |  |  |  |  |  |  |  |  |  |  |  |  |  |  |  |  |  |
|  | 1 | **1.4.2.2.4.1 HIGH THRESHOLD CC** |  |  | 2009-08-10 | 2015-06-19 |  |  |  |  |  |  |  |  |  |  |  |  |  |  |  |  |  |  |  |  |  |  |  |  |  |  |  |  |  |  |  |  |  |  |
| 142241000M |  | HTCC-P-#1 Start Procurement Prep PMTs | milestone | 0d | 2009-08-10 A | 2009-08-10 A | 9-100M FS-60d, 1222241035M FS+39d | 100% | 2009-09-01 | 2009-09-01 |  |  |  | 0 | ELOUADRHIRI L | 1 | 1 | 6 | M | LATIFA E | 08-052 | 11-026 | 11 -035 | 12-007 |  |  |  |  |  |  |  |  |  |  |  |  |  |  |  |  |
| 142241002 |  | HTCC-P-#1 Procumnt Prep for Mirror Compnts, Tooling and PMTs FY09 |  | 128.15d | 2009-08-17 A | 2010-02-26 A | 142241000M | 100% |  |  | SCIENTIST [65.33 h] | 4,298.59 | 4,298.59 | 4198.1058 | ELOUADRHIRI L | 1 | 1 |  | H | LATIFA E |  | 11-026 | 11 -035 | 12-007 | 0 | 10-001B |  |  |  |  |  |  |  |  |  |  |  |  |  |  |
| 142241002b |  | HTCC-P-#1 Procumnt Prep for Mirror Compnts, Tooling and PMTs FY10 |  | 97.57d | 2009-09-30 A | 2010-02-26 A | 142241002 FS-300d | 100% |  |  | SCIENTIST [14.67 h] | 972.46 | 972.46 | 972.7677 | ELOUADRHIRI L | 1 | 1 |  | H | LATIFA E |  | 11-026 | 11 -035 | 12-007 | 0 | 10-001B |  |  |  |  |  |  |  |  |  |  |  |  |  |  |
| 142241026M |  | HTCC-P-#2 Start Construction | milestone | 0d | 2009-10-01 A | 2009-10-01 A | 9-100M | 100% | 2009-11-06 | 2009-11-06 |  |  |  | 0 | ELOUADRHIRI L | 1 | 1 | 6 | M | LATIFA E |  | 11-026 | 11 -035 | 12-007 |  |  |  |  |  |  |  |  |  |  |  |  |  |  |  |  |
| 142241102 |  | HTCC-P-#2 Procumnt Prep for Mirror Compnts & Tooling |  | 112d | 2009-10-01 A | 2010-03-19 A | 142241026M | 100% |  |  | SCIENTIST [40 h] | 2,652.4 | 2,652.4 | 2652.4 | ELOUADRHIRI L | 1 | 1 |  | H | LATIFA E |  | 11-026 | 11 -035 | 12-007 | 0 |  |  |  |  |  |  |  |  |  |  |  |  |  |  |  |
| 142241005 |  | HTCC-P-#1 Vend Manufacturing of Mirror Compnts & Tooling |  | 71d | 2009-12-01 A | 2010-03-19 A | 142241002b, 9-100M | 100% |  |  | SUPPLIES & MATERIALS | 37,809.21 |  | 37809.21 | ELOUADRHIRI L | 1 | 1 |  | D | LATIFA E |  | 11-026 | 11 -035 | 12-007 | 0 |  | APP | 10-016 |  |  |  |  |  |  |  |  |  |  |  |  |
| 142241105 |  | HTCC-P-#2 Vend Manufacturing of Mirror Compnts & Tooling |  | 33d | 2010-03-01 A | 2010-04-14 A | 9-100M FS+55d, 142241102 | 100% |  |  | SUPPLIES & MATERIALS | 37,809.21 |  | 37809.21 | ELOUADRHIRI L | 1 | 1 |  | S | LATIFA E |  | 11-026 | 11 -035 | 12-007 | 0 |  | APP | 10-016 | ST |  |  |  |  |  |  |  |  |  |  |  |
| 142241580 |  | Procurement of miscellaneous parts - Proc |  | 913d | 2010-03-08 A | 2013-08-30 A | 9-100M FS+103d | 100% | 2010-03-08 | 2013-11-01 | PROCUREMENT<$50K 60 NO ESCALATION FY11 | 70.18 |  | 70.18 | ELOUADRHIRI L | 1 | 1 |  | D | LATIFA E |  | 11-026 | 11 -035 | 12-007 | 1300 |  |  | 10-016 |  | 0 | 70.18 | 7018 | 100 |  |  |  |  |  |  |  |
| 142241250 |  | Assembly of the mirror #1 substrate - Lab |  | 257d | 2010-04-13 A | 2011-04-25 A | 142241105 FS-14d | 100% |  |  | SCIENTIST [40 h] | 2,697.6 | 2,697.6 | 2652.4 | ELOUADRHIRI L | 1 | 1 |  | H | LATIFA E |  | 11-026 | 11 -035 | 12-007 | 0 |  |  | 10-016 |  |  |  |  |  |  |  |  |  |  |  |  |
| 142241210 |  | Manufacturing of the 5" PMT ET-9823QB and HV dividers - Proc |  | 303d | 2010-04-14 A | 2011-06-30 A | 142241005 FS-50d | 100% |  |  | PROCUREMENT<$50K 60 NO ESCALATION FY11; PROCUREMENT>$50K 69 NO ESCALATION FY11 | 364,000 |  | 364000 | ELOUADRHIRI L | 1 | 1 |  | D | LATIFA E |  | 11-026 | 11 -035 | 12-007 | 0 |  |  | 10-016 |  | 0 | 364000 | 36400000 | 100 |  |  |  |  |  |  |  |
| 142241350M |  | Space required for HTCC construction | milestone | 0d | 2010-05-24 A | 2010-05-24 A | 9-100M FS+97d | 100% | 2010-06-01 | 2010-06-01 |  |  |  | 0 | ELOUADRHIRI L | 1 | 1 |  | M | LATIFA E |  | 11-026 | 11 -035 | 12-007 |  |  |  | 10-016 |  |  |  |  |  |  |  |  |  |  |  |  |
| 142241465 |  | Procurement Prep for magnetic shields - Lab |  | 393d | 2010-05-24 A | 2011-12-19 A | 142241210 FS-296d | 100% |  |  | SCIENTIST [40 h] | 2,729.55 | 2,729.55 | 2652.4 | ELOUADRHIRI L | 1 | 1 |  | H | LATIFA E |  | 11-026 | 11 -035 | 12-007 | 0 |  |  | 10-016 |  |  |  |  |  |  |  |  |  |  |  |  |
| 142241360 |  | Transport of all necessary equipment from Test area (room 125, EEL) to the HTCC assembly area |  | 89d | 2010-05-25 A | 2010-09-29 A | 142241350M | 100% |  |  |  |  |  | 0 | ELOUADRHIRI L | 1 | 1 |  | Z | LATIFA E |  | 11-026 | 11 -035 | 12-007 |  |  |  | 10-016 |  |  |  |  |  |  |  |  |  |  |  |  |
| 142241365 |  | Installation of all equipment for all the HTCC equipment and safety review |  | 89d | 2010-05-25 A | 2010-09-29 A | 142241360 FS-116d | 100% |  |  |  |  |  | 0 | ELOUADRHIRI L | 1 | 1 |  | Z | LATIFA E |  | 11-026 | 11 -035 | 12-007 |  |  |  | 10-016 |  |  |  |  |  |  |  |  |  |  |  |  |
| 142241265 |  | Tooling manufacturing for mirror segments construction - Lab |  | 41d | 2010-07-05 A | 2010-08-31 A | 142241260 FS-30d | 100% | 2010-07-06 | 2010-08-31 | SCIENTIST [80 h]; MECH DES [40 h] | 7,114.4 | 7,114.4 | 7114.4 | ELOUADRHIRI L | 1 | 1 |  | H | LATIFA E |  | 11-026 | 11 -035 | 12-007 | 0 |  |  | 10-016 |  |  |  |  |  |  |  |  |  |  |  |  |
| 142241354 |  | HTCC Prepare Mezzanine workspace |  | 113d | 2010-07-12 A | 2010-12-20 A | 9-100M FS+184d | 100% |  |  | PROCUREMENT<$50K 60 NO ESCALATION FY11; PROCUREMENT>$50K 69 NO ESCALATION FY11 | 70,000 |  | 70000 | ELOUADRHIRI L | 1 | 1 |  | D | LATIFA E |  | 11-026 | 11 -035 | 12-007 | 0 |  |  |  |  | 0 | 70000 | 7000000 | 100 | 10-060 |  |  |  |  |  |  |
| 142241310 |  | Procurement Prep of ROHACELL foam sheets for substrates manufacturing - Lab |  | 40d | 2010-08-23 A | 2010-10-18 A | 142241260 FS-60d | 100% |  |  | SCIENTIST [20 h] | 1,338.92 | 1,338.92 | 1326.2 | ELOUADRHIRI L | 1 | 1 |  | H | LATIFA E |  | 11-026 | 11 -035 | 12-007 | 0 |  |  | 10-016 |  |  |  |  |  |  |  |  |  |  |  |  |
| 142241260 |  | Quality control of the mirror #1 substrate - Lab |  | 180d | 2010-08-30 A | 2011-05-23 A | 142241250 FS-60d | 100% |  |  | SCIENTIST [40 h] | 2,726.36 | 2,726.36 | 2652.4 | ELOUADRHIRI L | 1 | 1 |  | H | LATIFA E |  | 11-026 | 11 -035 | 12-007 | 0 |  |  | 10-016 |  |  |  |  |  |  |  |  |  |  |  |  |
| 142241320 |  | Procurement Prep of plastic monomers (acrylic and / or epoxy with low vapor pressure) - Lab |  | 139d | 2010-08-30 A | 2011-03-25 A | 142241260 FS-60d | 100% |  |  | SCIENTIST [20 h] | 1,361.58 | 1,361.58 | 1326.2 | ELOUADRHIRI L | 1 | 1 |  | H | LATIFA E |  | 11-026 | 11 -035 | 12-007 | 0 |  |  | 10-016 |  |  |  |  |  |  |  |  |  |  |  |  |
| 142241330 |  | Procurement prep of plastic films/sheets of optical quality - Lab |  | 23d | 2010-08-30 A | 2010-09-30 A | 142241260 FS-60d | 100% |  |  | SCIENTIST [10 h] | 663.1 | 663.1 | 663.1 | ELOUADRHIRI L | 1 | 1 |  | H | LATIFA E |  | 11-026 | 11 -035 | 12-007 | 0 |  |  | 10-016 |  |  |  |  |  |  |  |  |  |  |  |  |
| 142241270 |  | Manufacturing of tooling for mirror segments construction - Expenses FY10 |  | 333d | 2010-09-06 A | 2012-01-16 A | 142241265 FS-30d | 100% | 2010-09-07 | 2012-01-13 | MSHOP | 14,044.07 |  | 14044.07 | ELOUADRHIRI L | 1 | 1 |  | H | LATIFA E |  | 11-026 | 11 -035 | 12-007 | 0 |  |  | 10-016 |  |  |  |  |  |  | 11-001 |  |  |  |  |  |
| 142241270a |  | Manufacturing of tooling for mirror segments construction - Expenses FY11 |  | 333d | 2010-09-06 A | 2012-01-16 A | 142241265 FS-185d, 142241270 FS-155d | 100% | 2010-09-07 | 2012-01-13 | MSHOP | 6,587.31 |  | 6587.31 | ELOUADRHIRI L | 1 | 1 |  | H | LATIFA E |  | 11-026 | 11 -035 | 12-007 | 0 |  |  | 10-016 |  |  |  |  |  |  | 11-001 |  |  |  |  |  |
| 142241435 |  | Procurement prep of CV construction parts - Lab FY10 |  | 527.65d | 2010-09-06 A | 2012-10-19 A | 142241430M FS-70d | 100% | 2010-09-07 | 2012-10-19 | SCIENTIST [11.39 h]; MECH ENG [11.39 h]; MECH DES [11.39 h] | 2,117.75 | 2,117.75 | 2020.586 | ELOUADRHIRI L | 1 | 1 |  | H | LATIFA E |  | 11-026 | 11 -035 | 12-007 | 0 |  |  | 10-016 |  |  |  |  |  |  | 11-001 | 12-054F |  |  |  |  |
| 142241435a |  | Procurement prep of CV construction parts - Lab FY11 |  | 528d | 2010-09-06 A | 2012-10-19 A | 142241435 FS-70d | 100% | 2010-09-07 | 2012-10-19 | SCIENTIST [28.61 h]; MECH ENG [28.61 h]; MECH DES [28.61 h] | 5,319.63 | 5,319.63 | 5237.3466 | ELOUADRHIRI L | 1 | 1 |  | H | LATIFA E |  | 11-026 | 11 -035 | 12-007 | 0 |  |  | 10-016 |  |  |  |  |  |  | 11-001 | 12-054F |  |  |  |  |
| 142241325 |  | Procurement of plastic monomers (acrylic and / or epoxy with low vapor pressure) - Proc |  | 133d | 2010-09-08 A | 2011-03-25 A | 142241320 FS-40d | 100% |  |  | PROCUREMENT<$50K 60 | 500 |  | 500 | ELOUADRHIRI L | 1 | 1 |  | D | LATIFA E |  | 11-026 | 11 -035 | 12-007 | 0 |  |  | 10-016 |  | 0 | 500 | 50000 | 100 |  |  |  |  |  |  |  |
| 142241315 |  | Procurement of ROHACELL foam sheets for substrates manufacturing - Proc |  | 87d | 2010-09-13 A | 2011-01-24 A | 142241310 FS-40d | 100% |  |  | PROCUREMENT<$50K 60 | 4,200 |  | 4200 | ELOUADRHIRI L | 1 | 1 |  | D | LATIFA E |  | 11-026 | 11 -035 | 12-007 | 0 |  |  | 10-016 |  | 0 | 4200 | 420000 | 100 |  |  |  |  |  |  |  |
| 142241335 |  | Procurement of plastic films/sheets of optical quality - Proc |  | 51d | 2010-09-13 A | 2010-11-22 A | 142241330 FS-40d | 100% |  |  | PROCUREMENT<$50K 60 | 2,200 |  | 2200 | ELOUADRHIRI L | 1 | 1 |  | D | LATIFA E |  | 11-026 | 11 -035 | 12-007 | 0 |  |  | 10-016 |  | 0 | 2200 | 220000 | 100 |  |  |  |  |  |  |  |
| 142241355 |  | Procurement of Granite Tables - Proc |  | 69d | 2010-09-13 A | 2010-12-20 A | 142241350M | 100% |  |  | PROCUREMENT<$50K 60 NO ESCALATION FY11 | 10,000 |  | 10000 | ELOUADRHIRI L | 1 | 1 |  | D | LATIFA E |  | 11-026 | 11 -035 | 12-007 | 0 |  |  | 10-016 |  | 0 | 10000 | 1000000 | 100 |  |  |  |  |  |  |  |
| 142241475 |  | Tests of up to 10% of magnetic shields - Lab FY10 |  | 391.58d | 2010-09-14 A | 2012-04-16 A | 142241470 FS-225d | 100% |  |  | PD UNIV STUDNT [32.91 h]; CONTRB UNIV LBR [16.45 h] | 343.56 | 343.56 | 329.7582 | ELOUADRHIRI L | 1 | 1 |  | H | LATIFA E |  | 11-026 | 11 -035 | 12-007 | 0 |  |  | 10-016 |  |  |  |  |  |  | 11-001 |  |  |  |  |  |
| 142241475a |  | Tests of up to 10% of magnetic shields - Lab FY11 |  | 392d | 2010-09-14 A | 2012-04-16 A | 142241475 FS-183d | 100% |  |  | PD UNIV STUDNT [47.09 h]; CONTRB UNIV LBR [23.55 h] | 491.6 | 491.6 | 486.9106 | ELOUADRHIRI L | 1 | 1 |  | H | LATIFA E |  | 11-026 | 11 -035 | 12-007 | 0 |  |  | 10-016 |  |  |  |  |  |  | 11-001 |  |  |  |  |  |
| 142241480 |  | Procurement Prep of Light Collectors (WC) - Lab |  | 97d | 2011-02-14 A | 2011-06-30 A | 9-110M FS+38d | 100% |  |  | SCIENTIST [16 h]; CONTRB UNIV LBR [80 h] | 1,094.88 | 1,094.88 | 1094.88 | ELOUADRHIRI L | 1 | 1 |  | H | LATIFA E |  | 11-026 | 11 -035 | 12-007 | 0 |  |  | 10-016 |  |  |  |  |  |  |  |  |  |  |  |  |
| 142241255 |  | Trimming of the mirror #1 substrate -Expenses |  | 41d | 2011-03-21 A | 2011-05-16 A | 142241250 FS-20d | 100% |  |  | MSHOP | 500 |  | 500 | ELOUADRHIRI L | 1 | 1 |  | H | LATIFA E |  | 11-026 | 11 -035 | 12-007 | 0 |  |  | 10-016 |  |  |  |  |  |  |  | 12-054F |  |  |  |  |
| 142241340 |  | Manufacturing of foam mirror substrates - Expenses FY10 |  | 74.5d | 2011-04-01 A | 2011-07-18 A | 142241315 FS-1d, 142241275a FS-110d, 142241275 FS-110d, 142241335 FS-1d | 100% |  |  | MSHOP | 779.22 |  | 779.22 | ELOUADRHIRI L | 1 | 1 |  | D | LATIFA E |  | 11-026 | 11 -035 | 12-007 | 0 |  |  | 10-016 |  |  |  |  |  |  | 11-001 |  |  |  |  |  |
| 142241345 |  | Quality control of cut mirror substrates - Lab FY10 |  | 74d | 2011-04-04 A | 2011-07-18 A | 142241340a FS-154d, 142241340 FS-154d | 100% |  |  | SCIENTIST [0.39 h] | 26.69 | 26.69 | 25.8609 | ELOUADRHIRI L | 1 | 1 |  | H | LATIFA E |  | 11-026 | 11 -035 | 12-007 | 0 |  |  | 10-016 |  |  |  |  |  |  | 11-001 |  |  |  |  |  |
| 142241345a |  | Quality control of cut mirror substrates - Lab FY11 |  | 321d | 2011-04-04 A | 2012-07-16 A | 142241340a FS-180d, 142241345 | 100% |  |  | SCIENTIST [59.61 h] | 4,157.65 | 4,157.65 | 4079.1123 | ELOUADRHIRI L | 1 | 1 |  | H | LATIFA E |  | 11-026 | 11 -035 | 12-007 | 0 |  |  | 10-016 |  |  |  |  |  |  | 11-001 |  |  |  |  |  |
| 142241340a |  | Manufacturing of foam mirror substrates - Expenses FY11 |  | 320.5d | 2011-04-04 A | 2012-07-16 A | 142241275a FS-140d, 142241275 FS-140d | 100% |  |  | MSHOP | 123,023.92 |  | 123023.92 | ELOUADRHIRI L | 1 | 1 |  | D | LATIFA E |  | 11-026 | 11 -035 | 12-007 | 0 |  |  | 10-016 |  |  |  |  |  |  | 11-001 |  |  |  |  |  |
| 142241370 |  | Assembly of 12 identical sets and QA of 5 substrates (60 substrates total) - Lab FY11 |  | 174d | 2011-05-02 A | 2012-01-16 A | 142241365, 142241354 FS-70d, 142241270a FS-150d, 142241325 FS+9d, 142241270 FS-150d | 100% | 2011-05-02 | 2012-01-13 | SCIENTIST [328.04 h]; MECH ENG [15.62 h]; MECH TECH [999.74 h]; VISTNG USERS [1099.71 h] | 88,235.4 | 88,235.4 | 87165.5263 | ELOUADRHIRI L | 1 | 1 |  | U | LATIFA E |  | 11-026 | 11 -035 | 12-007 | 0 |  |  | 10-016 |  |  |  |  |  |  |  |  | 12-001 |  |  |  |
| 142241370a |  | Assembly of 12 identical sets and QA of 5 substrates (60 substrates total) - Lab FY12 |  | 174d | 2011-05-02 A | 2012-01-16 A | 142241370 FS-230d | 100% | 2011-05-02 | 2012-01-13 | SCIENTIST [28.82 h]; MECH ENG [1.37 h]; MECH TECH [87.84 h]; VISTNG USERS [96.63 h] | 7,752.39 | 7,752.39 | 7902.769333 | ELOUADRHIRI L | 1 | 1 |  | U | LATIFA E |  | 11-026 | 11 -035 | 12-007 | 0 |  |  | 10-016 |  |  |  |  |  |  |  |  | 12-001 |  |  |  |
| 142241375 |  | Tests of assembled substrates - Lab FY11 |  | 365d | 2011-05-02 A | 2012-10-15 A | 142241365 FS-10d, 142241270a FS-150d, 142241270 FS-150d | 100% |  |  | MECH TECH [30.25 h]; SCIENTIST [30.25 h]; VISTNG USERS [151.27 h] | 6,352.4 | 6,352.4 | 6206.1621 | ELOUADRHIRI L | 1 | 1 |  | U | LATIFA E |  | 11-026 | 11 -035 | 12-007 | 0 |  |  | 10-016 |  |  |  |  |  |  |  |  | 12-001 |  |  |  |
| 142241375a |  | Tests of assembled substrates - Lab FY12 |  | 365d | 2011-05-02 A | 2012-10-15 A | 142241375 FS-210d | 100% |  |  | VISTNG USERS [48.73 h]; MECH TECH [9.75 h]; SCIENTIST [9.75 h] | 2,046.96 | 2,046.96 | 2063.6884 | ELOUADRHIRI L | 1 | 1 |  | U | LATIFA E |  | 11-026 | 11 -035 | 12-007 | 0 |  |  | 10-016 |  |  |  |  |  |  |  |  | 12-001 |  |  |  |
| 142241275 |  | Quality Control of tooling for mirror segments construction - Lab FY10 |  | 344d | 2011-06-01 A | 2012-10-15 A | 142241265, 9-110M FS+153d | 100% |  |  | SCIENTIST [33.85 h] | 2,374.14 | 2,374.14 | 2244.5935 | ELOUADRHIRI L | 1 | 1 |  | H | LATIFA E |  | 11-026 | 11 -035 | 12-007 | 0 |  |  | 10-016 |  |  |  |  |  |  | 11-001 |  |  |  |  |  |
| 142241275a |  | Quality Control of tooling for mirror segments construction - Lab FY11 |  | 344d | 2011-06-01 A | 2012-10-15 A | 142241265 FS-30d, 142241275 FS-142d | 100% |  |  | SCIENTIST [16.15 h] | 1,132.71 | 1,132.71 | 1105.1445 | ELOUADRHIRI L | 1 | 1 |  | H | LATIFA E |  | 11-026 | 11 -035 | 12-007 | 0 |  |  | 10-016 |  |  |  |  |  |  | 11-001 |  |  |  |  |  |
| 142241380 |  | Precision trimming of 12 identical sets of 5 substrates (60 substrates total) - Expenses FY11 |  | 364d | 2011-06-01 A | 2012-11-12 A | 142241270a FS-150d, 142241270 FS-150d, 142241365 | 100% |  |  | MSHOP | 14,710.27 |  | 14710.27 | ELOUADRHIRI L | 1 | 1 |  | U | LATIFA E |  | 11-026 | 11 -035 | 12-007 | 0 |  |  | 10-016 |  |  |  |  |  |  |  |  | 12-001 |  |  |  |
| 142241380a |  | Precision trimming of 12 identical sets of 5 substrates (60 substrates total) - Expenses FY12 |  | 364d | 2011-06-01 A | 2012-11-12 A | 142241380 FS-250d | 100% |  |  | MSHOP | 5,264.97 |  | 5264.97 | ELOUADRHIRI L | 1 | 1 |  | U | LATIFA E |  | 11-026 | 11 -035 | 12-007 | 0 |  |  | 10-016 |  |  |  |  |  |  |  |  | 12-001 |  |  |  |
| 142241385 |  | Quality control of trimmed substrates before deposition of coating - Labor FY11 |  | 368.53d | 2011-06-01 A | 2012-11-19 A | 142241370a FS-415d, 142241370 FS-415d, 142241380a FS-447.5d, 142241270 FS-150d, 142241365, 142241270a FS-150d | 100% |  |  | MECH ENG [25.85 h]; SCIENTIST [25.85 h] | 3,622.81 | 3,622.81 | 3525.423 | ELOUADRHIRI L | 1 | 1 |  | H | LATIFA E |  | 11-026 | 11 -035 | 12-007 | 0 |  |  | 10-016 |  |  |  |  |  |  |  | 12-054F | 12-001 |  |  |  |
| 142241385a |  | Quality control of trimmed substrates before deposition of coating - Labor FY12 |  | 369d | 2011-06-01 A | 2012-11-19 A | 142241385 FS-250d | 100% |  |  | SCIENTIST [14.15 h]; MECH ENG [14.15 h] | 1,983.18 | 1,983.18 | 1991.3295 | ELOUADRHIRI L | 1 | 1 |  | H | LATIFA E |  | 11-026 | 11 -035 | 12-007 | 0 |  |  | 10-016 |  |  |  |  |  |  |  | 12-054F | 12-001 |  |  |  |
| 142241485 |  | Manufacturing of Light Collectors (WC) - Proc |  | 280d | 2011-06-01 A | 2012-07-16 A | 142241480 | 100% |  |  | PROCUREMENT<$50K 60 NO ESCALATION FY12 | 23,836.89 |  | 23836.89 | ELOUADRHIRI L | 1 | 1 |  | D | LATIFA E |  | 11-026 | 11 -035 | 12-007 | 0 |  |  | 10-016 |  | 0 | 23836.89 | 2383689 | 100 |  |  |  |  |  |  |  |
| 142241495 |  | Procurement support of cables and gas systems - Lab FY10 |  | 173d | 2011-06-01 A | 2012-02-13 A | 9-100M FS+205d | 100% |  |  | MECH TECH [76.44 h]; SCIENTIST [38.22 h] | 6,002.23 | 6,002.23 | 5724.9738 | ELOUADRHIRI L | 1 | 1 |  | H | LATIFA E |  | 11-026 | 11 -035 | 12-007 | 0 |  |  | 10-016 |  |  |  |  |  |  | 11-001 |  |  |  |  |  |
| 142241495a |  | Procurement support of cables and gas systems - Lab FY11 |  | 172d | 2011-06-01 A | 2012-02-13 A | 142241495 FS-464d | 100% |  |  | SCIENTIST [1.78 h]; MECH TECH [3.56 h] | 279.52 | 279.52 | 275.1346 | ELOUADRHIRI L | 1 | 1 |  | H | LATIFA E |  | 11-026 | 11 -035 | 12-007 | 0 |  |  | 10-016 |  |  |  |  |  |  | 11-001 |  |  |  |  |  |
| 142241280 |  | Tooling Design for mirror half-sectors assembly - Lab FY10 |  | 49d | 2011-07-18 A | 2011-09-26 A | 9-110M FS+153d, 142241265 FS+19d | 100% | 2011-07-18 | 2011-09-23 | SCIENTIST [33.33 h]; MECH DES [16.67 h]; MECH ENG [16.67 h] | 4,191.66 | 4,191.66 | 4061.9826 | ELOUADRHIRI L | 1 | 1 |  | H | LATIFA E |  | 11-026 | 11 -035 | 12-007 | 0 |  |  | 10-016 |  |  |  |  |  |  | 11-001 |  |  |  |  |  |
| 142241280a |  | Tooling Design for mirror half-sectors assembly - Lab FY11 |  | 49d | 2011-07-18 A | 2011-09-26 A | 142241280 FS-140d, 142241265 FS-90d | 100% | 2011-07-18 | 2011-09-23 | SCIENTIST [46.67 h]; MECH DES [23.33 h]; MECH ENG [23.33 h] | 5,867.94 | 5,867.94 | 5867.946 | ELOUADRHIRI L | 1 | 1 |  | H | LATIFA E |  | 11-026 | 11 -035 | 12-007 | 0 |  |  | 10-016 |  |  |  |  |  |  | 11-001 |  |  |  |  |  |
| 142241430M |  | Start Manufacturing of the Containment Vessel | milestone | 0d | 2011-08-15 A | 2011-08-15 A | 9-100M FS+205d, 9-110M FS+230d | 100% | 2011-09-07 | 2011-09-07 |  |  |  | 0 | ELOUADRHIRI L | 1 | 1 |  | M | LATIFA E |  | 11-026 | 11 -035 | 12-007 |  |  |  | 10-016 |  |  |  |  |  |  |  | 12-054F |  |  |  |  |
| 142241285 |  | Manufacturing of tooling for mirror half sectors assembly - Expenses |  | 333d | 2011-09-24 A | 2013-01-21 A | 142241280a, 142241280 | 100% | 2011-09-26 | 2013-02-01 | MSHOP | 22,289.04 |  | 22289.04 | ELOUADRHIRI L | 1 | 1 |  | H | LATIFA E |  | 11-026 | 11 -035 | 12-007 | 0 |  |  | 10-016 |  |  |  |  |  |  |  |  |  | XX |  |  |
| 142241290 |  | Quality Control of tooling for mirror half-sectors assembly - Lab |  | 328d | 2011-10-03 A | 2013-01-21 A | 142241280 FS+20d, 142241280a FS+20d | 100% | 2011-10-03 | 2013-02-01 | SCIENTIST [45 h] | 3,202.45 | 3,200.3 | 3079.35 | ELOUADRHIRI L | 1 | 1 |  | H | LATIFA E |  | 11-026 | 11 -035 | 12-007 | 0 |  |  | 10-016 |  |  |  |  |  |  |  |  |  | XX |  |  |
| 142241295 |  | Tooling manufacturing for combined mirror assembly - Lab |  | 346d | 2011-10-03 A | 2013-05-13 A | 142241290 FS-79d | 100% | 2011-10-03 | 2013-02-28 | SCIENTIST [80 h]; MECH ENG [80 h]; MECH DES [80 h] | 15,250.02 | 15,295.02 | 14644.8 | ELOUADRHIRI L | 1 | 1 |  | H | LATIFA E |  | 11-026 | 11 -035 | 12-007 | 0 |  |  | 10-016 |  |  |  |  |  |  |  |  |  | XX |  |  |
| 142241300 |  | Manufacturing of tooling for combined mirror assembly - Expenses FY11 |  | 87d | 2011-10-03 A | 2012-02-13 A | 142241295 FS-170d | 100% |  |  | MSHOP | 22,317.83 |  | 22317.83 | ELOUADRHIRI L | 1 | 1 |  | H | LATIFA E |  | 11-026 | 11 -035 | 12-007 | 0 |  |  | 10-016 |  |  |  |  |  |  |  |  | 12-001 |  |  |  |
| 142241300a |  | Manufacturing of tooling for combined mirror assembly - Expenses FY12 |  | 87d | 2011-10-03 A | 2012-02-13 A | 142241300 FS-70d | 100% |  |  | MSHOP | 8,914.76 |  | 8914.76 | ELOUADRHIRI L | 1 | 1 |  | H | LATIFA E |  | 11-026 | 11 -035 | 12-007 | 0 |  |  | 10-016 |  |  |  |  |  |  |  |  | 12-001 |  |  |  |
| 142241305 |  | Quality Control of tooling for combined mirror assembly - Lab FY11 |  | 347d | 2011-10-03 A | 2013-05-13 A | 142241300a FS-140d, 142241295 FS-170d | 100% | 2011-10-03 | 2013-03-01 | SCIENTIST [42.27 h] | 3,012.09 | 3,020.77 | 2892.5361 | ELOUADRHIRI L | 1 | 1 |  | H | LATIFA E |  | 11-026 | 11 -035 | 12-007 | 0 |  |  | 10-016 |  |  |  |  |  |  |  |  | 12-001 |  |  |  |
| 142241305a |  | Quality Control of tooling for combined mirror assembly - Lab FY12 |  | 347d | 2011-10-03 A | 2013-05-13 A | 142241305 FS-150d | 100% | 2011-10-03 | 2013-03-01 | SCIENTIST [17.73 h] | 1,263.41 | 1,267.05 | 1251.9153 | ELOUADRHIRI L | 1 | 1 |  | H | LATIFA E |  | 11-026 | 11 -035 | 12-007 | 0 |  |  | 10-016 |  |  |  |  |  |  |  |  | 12-001 |  |  |  |
| 142241270b |  | Manufacturing of tooling for mirror segments construction - Expenses FY12 |  | 237d | 2011-11-01 A | 2012-10-15 A | 9-120M FS+21d | 100% |  |  | MSHOP | 47,500 |  | 47500 | ELOUADRHIRI L | 1 | 1 |  | H | LATIFA E |  | 11-026 | 11 -035 | 12-007 | 0 |  |  | 10-016 |  |  |  |  |  |  | 11-001 |  |  |  |  |  |
| 142241570 |  | Procurement Prep of the composite exit window - Lab |  | 33d | 2011-11-01 A | 2011-12-19 A | 9-120M | 100% |  |  | SCIENTIST [360 h] | 25,419.6 | 25,419.6 | 24634.8 | ELOUADRHIRI L | 1 | 1 |  | H | LATIFA E |  | 11-026 | 11 -035 | 12-007 | 0 |  |  | 10-016 |  |  |  |  |  |  |  |  |  |  |  |  |
| 142241487 |  | Manufacturing of Additional Light Collectors (WC) - Proc |  | 287d | 2011-12-01 A | 2013-06-17 A | 142241485 FS-237d | 100% | 2011-12-01 | 2013-02-01 | PROCUREMENT<$50K 60 | 32,750 |  | 32750 | ELOUADRHIRI L | 1 | 1 |  | D | LATIFA E |  | 11-026 | 11 -035 | 12-007 | 0 |  |  | 10-016 |  | 0 | 32750 | 3275000 | 100 |  |  |  |  | XX |  |  |
| 142241490 |  | Quality control of Light Collectors (WC) - Lab |  | 294d | 2011-12-19 A | 2013-08-30 A | 142241485 FS-172d, 142241487 FS-366d | 100% | 2011-12-19 | 2013-03-01 | CONTRB UNIV LBR [120 h] |  |  | 0 | ELOUADRHIRI L | 1 | 1 |  | Z | LATIFA E |  | 11-026 | 11 -035 | 12-007 |  |  |  | 10-016 |  |  |  |  |  |  |  |  |  |  |  |  |
| 142241302 |  | Procurement of Lab Equipment for Clean Rooms |  | 180d | 2012-01-03 A | 2012-09-17 A | 9-120M FS+60d | 100% |  |  | PROCUREMENT<$50K 60 | 31,000 |  | 31000 | ELOUADRHIRI L | 1 | 1 |  | D | LATIFA E |  | 11-026 | 11 -035 | 12-007 | 0 |  |  | 10-016 |  | 0 | 31000 | 3100000 | 100 |  |  |  |  |  |  |  |
| 142241440 |  | Manufacturing of parts for the CV construction - Proc Part A |  | 349d | 2012-01-03 A | 2013-05-13 A | 9-120M, 142241435a FS-70d | 100% | 2012-01-03 | 2013-05-24 | PROCUREMENT<$50K 60 NO ESCALATION FY13 | 10,000 |  | 10000 | ELOUADRHIRI L | 1 | 1 |  | D | LATIFA E |  | 11-026 | 11 -035 | 12-007 | 0 |  |  | 10-016 |  | 0 | 10000 | 1000000 | 100 |  |  | 12-054F |  |  | 12-055 |  |
| 142241445 |  | Manufacturing of Central Dish for the containment vessel - FY12 |  | 200d | 2012-01-03 A | 2012-10-15 A | 9-120M, 142241435a FS-70d | 100% |  |  | MSHOP | 31,058.8 |  | 31058.8 | ELOUADRHIRI L | 1 | 1 |  | D | LATIFA E |  | 11-026 | 11 -035 | 12-007 | 0 |  |  | 10-016 |  |  |  |  |  |  |  | 12-054F |  |  |  | 12-053 |
| 142241445a |  | Manufacturing of Central Dish for the containment vessel FY13 |  | 200d | 2012-01-03 A | 2012-10-15 A | 142241445 FS-190d | 100% |  |  | MSHOP | 29,864.42 |  | 29864.42 | ELOUADRHIRI L | 1 | 1 |  | D | LATIFA E |  | 11-026 | 11 -035 | 12-007 | 0 |  |  | 10-016 |  |  |  |  |  |  |  | 12-054F |  |  |  | 12-053 |
| 142241575 |  | Manufacturing of the composite exit window - Proc |  | 29d | 2012-01-03 A | 2012-02-13 A | 142241570 FS+25d | 100% |  |  | PROCUREMENT<$50K 60 NO ESCALATION FY13 | 22,000 |  | 22000 | ELOUADRHIRI L | 1 | 1 |  | D | LATIFA E |  | 11-026 | 11 -035 | 12-007 | 0 |  |  | 10-016 |  | 0 | 22000 | 2200000 | 100 |  |  |  |  |  |  |  |

Notes:
- 142241000M: Explanation: Title change 01 sept
- 142241002: Explanation: Title change 01 Sept
- 142241002b: Explanation: Title change 01 Sept
- 142241105: Steps: Procurement Prep of the 5" PMT ET-9823QB and HV dividers - Lab (done); Tooling manufacturing for mirror #1 substrate construction - Lab (done); Preparation of files for computer control machines - Proc (done); Manufacturing of components for mirror #1 construction - Expenses (done); Manufacturing of the 1st Article 5" PMT ET-9823QB and HV dividers - Proc (done); Quality control of manufacturing of components for mirror #1 construction - Lab (done)

| ID | Activity | Duration | Start | Finish | Predecessors | Complete | Remaining | Planned start | Planned finish | Total float | Free float | Calendar | Resources | Cost | Actual cost | Calculated Remaining Total Cost | MONTHLY EV COST | RESP - Responsibility | STRT%COMP for CM EVM | FNSH%COMP for CM EVM | EVMS Reporting Codes | CAM RESPONSIBLE | CR 10-016 | CR 11-026 | CR 11-035 | CR 12-001 | CR 12-007 | Remaining Material Cost Based on % Compl | Claimed Material Cost Based on % Complet | Initial Claimed Material Calc | Claimed Material Divider | CR 12-027 | CR 12-054 | CR 12-055 | CR 12-053 | Activities with Steps | ReBaseline Actuals Adjustment | Original Activity ID Rebaseline | PRIOR MONTH EV COST | CR 13-002 | BOE Labor | CR 13-015 | Post Rebaseline | CR 14-001 | BOE Expenses | BOE Procurement | Obligated Prior to Rebaseline |
| --- | --- | --- | --- | --- | --- | --- | --- | --- | --- | --- | --- | --- | --- | --- | --- | --- | --- | --- | --- | --- | --- | --- | --- | --- | --- | --- | --- | --- | --- | --- | --- | --- | --- | --- | --- | --- | --- | --- | --- | --- | --- | --- | --- | --- | --- | --- | --- |
| 142241370b | Assembly of 12 identical sets and QA of 5 substrates (60 substrates total) - Revised Lab FY12 | 191d | 2012-01-16 A | 2012-10-15 A | 142241370a | 100% |  | 2012-01-17 | 2012-10-15 |  |  |  | MECH ENG [3.01 h]; MECH TECH [2480 h]; VISTNG USERS [211.66 h]; SCIENTIST [560 h] | 154,338.58 | 154,338.58 | 0 | 154055.248618 | ELOUADRHIRI L | 1 | 1 | U | LATIFA E | 10-016 | 11-026 | 11 -035 | 12-001 | 12-007 |  |  |  |  |  |  |  |  |  |  |  |  |  |  |  |  |  |  |  |  |
| 142241470 | Manufacturing of magnetic shields - Proc | 64d | 2012-01-16 A | 2012-04-16 A | 142241465 FS+15d | 100% |  | 2012-01-17 | 2012-04-16 |  |  |  | PROCUREMENT>$50K 69 NO ESCALATION FY11; PROCUREMENT<$50K 60 NO ESCALATION FY11 | 64,800 |  | 0 | 64800 | ELOUADRHIRI L | 1 | 1 | D | LATIFA E | 10-016 | 11-026 | 11 -035 |  | 12-007 | 0 | 64800 | 6480000 | 100 |  |  |  |  |  |  |  |  |  |  |  |  |  |  |  |  |
| 142241527 | Procurement of components for the HTCC Gas System construction | 141d | 2012-02-01 A | 2012-08-20 A | 9-120M FS+80d | 100% |  |  |  |  |  |  | PROCUREMENT<$50K 60 NO ESCALATION FY13 | 20,000 |  | 0 | 20000 | ELOUADRHIRI L | 1 | 1 | D | LATIFA E | 10-016 | 11-026 | 11 -035 |  | 12-007 | 0 | 20000 | 2000000 | 100 |  |  |  |  |  |  |  |  |  |  |  |  |  |  |  |  |
| 142241647 | Proc. Prep of components for the HTCC Light Monitoring System | 91d | 2012-02-01 A | 2012-06-11 A | 9-120M FS+80d | 100% |  |  |  |  |  |  | MECH ENG [80 h] | 5,609.6 | 5,609.6 | 0 | 5609.6 | ELOUADRHIRI L | 1 | 1 | H | LATIFA E | 10-016 | 11-026 | 11 -035 |  | 12-007 |  |  |  |  |  |  |  |  |  |  |  |  |  |  |  |  |  |  |  |  |
| 142241530 | Manufacturing of Pump EW-07061-42 - Proc | 8d | 2012-02-01 A | 2012-02-13 A | 142241495a FS-380d | 100% |  |  |  |  |  |  | PROCUREMENT<$50K 60 | 410.7 |  | 0 | 410.7 | ELOUADRHIRI L | 1 | 1 | D | LATIFA E | 10-016 | 11-026 | 11 -035 |  | 12-007 | 0 | 410.7 | 41070 | 100 |  |  |  |  |  |  |  |  |  |  |  |  |  |  |  |  |
| 142241545 | Manufacturing of Transformer FF-108U Proc | 8d | 2012-02-01 A | 2012-02-13 A | 142241495a FS-380d | 100% |  |  |  |  |  |  | PROCUREMENT<$50K 60 | 29.93 |  | 0 | 29.93 | ELOUADRHIRI L | 1 | 1 | D | LATIFA E | 10-016 | 11-026 | 11 -035 |  |  | 0 | 29.93 | 2993 | 100 |  |  |  |  |  |  |  |  |  |  |  |  |  |  |  |  |
| 142241550 | Manufacturing of Utility Chasis CHA-5X21 - Proc | 8d | 2012-02-01 A | 2012-02-13 A | 142241495a FS-380d | 100% |  |  |  |  |  |  | PROCUREMENT<$50K 60 | 275.52 |  | 0 | 275.52 | ELOUADRHIRI L | 1 | 1 | D | LATIFA E | 10-016 | 11-026 | 11 -035 |  |  | 0 | 275.52 | 27552 | 100 |  |  |  |  |  |  |  |  |  |  |  |  |  |  |  |  |
| 142241555 | Manufacturing of Controller DP25B-EAR - Proc | 8d | 2012-02-01 A | 2012-02-13 A | 142241495a FS-380d | 100% |  |  |  |  |  |  | PROCUREMENT<$50K 60 | 407.6 |  | 0 | 407.6 | ELOUADRHIRI L | 1 | 1 | D | LATIFA E | 10-016 | 11-026 | 11 -035 |  |  | 0 | 407.6 | 40760 | 100 |  |  |  |  |  |  |  |  |  |  |  |  |  |  |  |  |
| 142241565 | Procurement of 1/2 Stainless Steel Tubing - Proc | 8d | 2012-02-01 A | 2012-02-13 A | 142241495a FS-380d | 100% |  |  |  |  |  |  | PROCUREMENT<$50K 60 | 1,362.11 |  | 0 | 1362.11 | ELOUADRHIRI L | 1 | 1 | D | LATIFA E | 10-016 | 11-026 | 11 -035 |  |  | 0 | 1362.11 | 136211 | 100 |  |  |  |  |  |  |  |  |  |  |  |  |  |  |  |  |
| 142241300b | Purchase of Pumps and Plumbing for Combined Mirror Assembly | 32d | 2012-03-02 A | 2012-04-16 A | 9-120M FS+80d | 100% |  |  |  |  |  |  | PROCUREMENT<$50K 60 | 38,000 |  | 0 | 38000 | ELOUADRHIRI L | 1 | 1 | D | LATIFA E | 10-016 | 11-026 | 11 -035 |  | 12-007 | 0 | 38000 | 3800000 | 100 |  |  |  |  |  |  |  |  |  |  |  |  |  |  |  |  |
| 142241500 | Manufacturing of high voltage (HV) cable RG8X - Proc | 12d | 2012-03-02 A | 2012-03-19 A | 142241495a FS-380d | 100% |  |  |  |  |  |  | PROCUREMENT<$50K 60 | 3,054.42 |  | 0 | 3054.42 | ELOUADRHIRI L | 1 | 1 | D | LATIFA E | 10-016 | 11-026 | 11 -035 |  | 12-007 | 0 | 3054.42 | 305442 | 100 |  |  |  |  |  |  |  |  |  |  |  |  |  |  |  |  |
| 142241505 | Manufacturing of signal cable PE-B319 - Proc | 12d | 2012-03-02 A | 2012-03-19 A | 142241495a FS-380d | 100% |  |  |  |  |  |  | PROCUREMENT<$50K 60 | 8,193.29 |  | 0 | 8193.29 | ELOUADRHIRI L | 1 | 1 | D | LATIFA E | 10-016 | 11-026 | 11 -035 |  | 12-007 | 0 | 8193.29 | 819329 | 100 |  |  |  |  |  |  |  |  |  |  |  |  |  |  |  |  |
| 142241510 | Manufacturing of HV connectors PE-4193 - Proc | 12d | 2012-03-02 A | 2012-03-19 A | 142241495a FS-380d | 100% |  |  |  |  |  |  | PROCUREMENT<$50K 60 | 532.46 |  | 0 | 532.46 | ELOUADRHIRI L | 1 | 1 | D | LATIFA E | 10-016 | 11-026 | 11 -035 |  | 12-007 | 0 | 532.46 | 53246 | 100 |  |  |  |  |  |  |  |  |  |  |  |  |  |  |  |  |
| 142241515 | Manufacturing of HV connectors PE-4493 - Proc | 12d | 2012-03-02 A | 2012-03-19 A | 142241495a FS-380d | 100% |  |  |  |  |  |  | PROCUREMENT<$50K 60 | 1,652.07 |  | 0 | 1652.07 | ELOUADRHIRI L | 1 | 1 | D | LATIFA E | 10-016 | 11-026 | 11 -035 |  | 12-007 | 0 | 1652.07 | 165207 | 100 |  |  |  |  |  |  |  |  |  |  |  |  |  |  |  |  |
| 142241520 | Manufacturing of BNC connectors PE-4386 - Proc | 12d | 2012-03-02 A | 2012-03-19 A | 142241495a FS-380d | 100% |  |  |  |  |  |  | PROCUREMENT<$50K 60 | 824.49 |  | 0 | 824.49 | ELOUADRHIRI L | 1 | 1 | D | LATIFA E | 10-016 | 11-026 | 11 -035 |  | 12-007 | 0 | 824.49 | 82449 | 100 |  |  |  |  |  |  |  |  |  |  |  |  |  |  |  |  |
| 142241525 | Manufacturing of BNC connectors PE-4014 - Proc | 12d | 2012-03-02 A | 2012-03-19 A | 142241495a FS-380d | 100% |  |  |  |  |  |  | PROCUREMENT<$50K 60 | 176.45 |  | 0 | 176.45 | ELOUADRHIRI L | 1 | 1 | D | LATIFA E | 10-016 | 11-026 | 11 -035 |  | 12-007 | 0 | 176.45 | 17645 | 100 |  |  |  |  |  |  |  |  |  |  |  |  |  |  |  |  |
| 142241560 | Manufacturing of Cable 1255/8BK002 - Proc | 12d | 2012-03-02 A | 2012-03-19 A | 142241495a FS-380d | 100% |  |  |  |  |  |  | PROCUREMENT<$50K 60 | 2,031.81 |  | 0 | 2031.81 | ELOUADRHIRI L | 1 | 1 | D | LATIFA E | 10-016 | 11-026 | 11 -035 |  |  | 0 | 2031.81 | 203181 | 100 |  |  |  |  |  |  |  |  |  |  |  |  |  |  |  |  |
| 142241647a | Proc of components for the HTCC Light Monitoring System | 188d | 2012-06-01 A | 2013-08-30 A | 142241647 | 100% |  | 2012-06-01 | 2013-03-07 |  |  |  | PROCUREMENT<$50K 60 | 9,080.72 |  | 4540.36 | 9080.72 | ELOUADRHIRI L | 1 | 1 | D | LATIFA E | 10-016 | 11-026 | 11 -035 |  | 12-007 | 0 | 9080.72 | 908072 | 100 | 12-027 |  |  |  |  |  |  |  |  |  |  |  |  |  |  |  |
| 142241472 | Procurement of PS for Compensation Coils | 75d | 2012-07-02 A | 2012-10-15 A | 9-130M FS-40d | 100% |  |  |  |  |  |  | PROCUREMENT<$50K 60 | 6,191.4 |  | 0 | 6191.4 | ELOUADRHIRI L | 1 | 1 | D | LATIFA E | 10-016 | 11-026 | 11 -035 |  | 12-007 | 0 | 6191.4 | 619140 | 100 |  |  |  |  |  |  |  |  |  |  |  |  |  |  |  |  |
| 142241535 | Manufacturing of Power Supply S-240-15 - Proc | 10d | 2012-09-03 A | 2012-09-17 A | 142241495a FS-380d, 9-130M | 100% |  | 2012-09-04 | 2012-09-17 |  |  |  | PROCUREMENT<$50K 60 | 95.97 |  | 0 | 95.97 | ELOUADRHIRI L | 1 | 1 | D | LATIFA E | 10-016 | 11-026 | 11 -035 |  |  | 0 | 95.97 | 9597 | 100 |  |  |  |  |  |  |  |  |  |  |  |  |  |  |  |  |
| 142241540 | Manufacturing of Controller 250E-4-D - Proc | 10d | 2012-09-03 A | 2012-09-17 A | 142241495a FS-380d, 9-130M | 100% |  | 2012-09-04 | 2012-09-17 |  |  |  | PROCUREMENT<$50K 60 | 2,575.62 |  | 0 | 2575.62 | ELOUADRHIRI L | 1 | 1 | D | LATIFA E | 10-016 | 11-026 | 11 -035 |  |  | 0 | 2575.62 | 257562 | 100 |  |  |  |  |  |  |  |  |  |  |  |  |  |  |  |  |
| 142241395 | Quality control of 60 coated substrates - Lab FY11 | 143d | 2012-10-01 A | 2013-08-30 A | 9-120M FS+80d | 100% |  | 2012-10-01 | 2013-05-01 |  |  |  | SCIENTIST [24.18 h] | 1,761.75 | 1,761.75 | 827.3187 | 1654.6374 | ELOUADRHIRI L | 1 | 1 | U | LATIFA E | 10-016 | 11-026 | 11 -035 | 12-001 | 12-007 |  |  |  |  |  |  |  |  |  |  |  |  |  |  |  |  |  |  |  |  |
| 142241395a | Quality control of 60 coated substrates - Lab FY12 | 143d | 2012-10-01 A | 2013-08-30 A | 142241395 FS-200d | 100% |  | 2012-10-01 | 2013-05-01 |  |  |  | SCIENTIST [15.82 h] | 1,152.65 | 1,152.65 | 558.5251 | 1117.0502 | ELOUADRHIRI L | 1 | 1 | U | LATIFA E | 10-016 | 11-026 | 11 -035 | 12-001 | 12-007 |  |  |  |  |  |  |  |  |  |  |  |  |  |  |  |  |  |  |  |  |
| 142241440a | Manufacturing of parts for the CV construction - Proc Part B | 160d | 2012-10-01 A | 2013-04-15 A | 142241435a FS-70d, 9-120M | 100% |  | 2012-10-01 | 2013-05-24 |  |  |  | PROCUREMENT<$50K 60 NO ESCALATION FY13; PROCUREMENT>$50K 69 NO ESCALATION FY13 | 90,000 |  | 0 | 90000 | ELOUADRHIRI L | 1 | 1 | D | LATIFA E | 10-016 | 11-026 | 11 -035 |  | 12-007 | 0 | 90000 | 9000000 | 100 |  | 12-054F | 12-055 |  |  |  |  |  |  |  |  |  |  |  |  |  |
| 142241382 | Precision trimming of 12 identical sets of 5 substrates (60 substrates total) - Additional Expenses FY12 | 6d | 2012-11-03 A | 2012-11-12 A | 142241370b FS-200d, 142241380a FS-15d, 142241270b FS-60d | 100% |  | 2012-11-05 | 2012-11-12 |  |  |  | MSHOP | 5,983.56 |  | 0 | 5983.56 | ELOUADRHIRI L | 1 | 1 | U | LATIFA E | 10-016 | 11-026 | 11 -035 |  | 12-007 |  |  |  |  |  |  |  | 12-053 |  |  |  |  |  |  |  |  |  |  |  |  |
| 142241382a | Precision trimming of 12 identical sets of 5 substrates (60 substrates total) - Additional Expenses FY13 | 11d | 2012-11-05 A | 2012-11-19 A | 142241382 | 100% |  |  |  |  |  |  | MSHOP | 726.42 |  | 0 | 726.42 | ELOUADRHIRI L | 1 | 1 | U | LATIFA E | 10-016 | 11-026 | 11 -035 |  | 12-007 |  |  |  |  |  |  |  | 12-053 |  |  |  |  |  |  |  |  |  |  |  |  |
| 142241450 | Assembly of the CV - Lab FY11 | 40d | 2013-05-06 A | 2013-08-30 A | 9-130M FS+5d, 9-120M, 142241440a FS-40d, 142241440 FS-40d, 142241445a FS-329d | 100% |  | 2013-07-02 | 2013-08-27 |  |  |  | MECH TECH [19.51 h]; VISTNG USERS [9.75 h]; SCIENTIST [4.88 h] | 1,444.8 | 1,444.8 | 678.4258 | 1356.8516 | ELOUADRHIRI L | 1 | 1 | H | LATIFA E | 10-016 | 11-026 | 11 -035 | 12-001 | 12-007 |  |  |  |  |  |  |  |  |  |  |  |  |  |  |  |  |  |  |  |  |
| 142241450a | Assembly of the CV - Lab FY12 | 40d | 2013-05-06 A | 2013-08-30 A | 142241450 FS-220d | 100% |  | 2013-07-02 | 2013-08-27 |  |  |  | MECH TECH [34.12 h]; VISTNG USERS [17.06 h]; SCIENTIST [8.53 h] | 2,526.59 | 2,526.59 | 1224.1726185 | 2448.345237 | ELOUADRHIRI L | 1 | 1 | H | LATIFA E | 10-016 | 11-026 | 11 -035 | 12-001 | 12-007 |  |  |  |  |  |  |  |  |  |  |  |  |  |  |  |  |  |  |  |  |
| 142241450b | Assembly of the CV - Lab Revised | 137d | 2013-05-06 A | 2013-08-30 A | 142241445a FS-123d, 142241450a FS-220d, 142241440a FS-90d, 142241440 FS-90d | 100% |  | 2013-08-28 | 2014-03-21 |  |  |  | MECH TECH [1120 h]; VISTNG USERS [133.19 h]; SCIENTIST [560 h] | 97,334.64 | 94,821.94 | 94821.9405 | 94821.9405 | ELOUADRHIRI L | 1 | 1 | S | LATIFA E | 10-016 | 11-026 | 11 -035 | 12-001 | 12-007 |  |  |  |  |  | 12-054 |  |  | ST |  |  |  |  |  |  |  |  |  |  |  |
| 142241455 | Quality control fo the CV construction - Lab | 118d | 2013-05-06 A | 2013-08-30 A | 142241450b FS-220d | 100% |  | 2013-09-04 | 2014-02-28 |  |  |  | SCIENTIST [31.52 h]; MECH DES [31.52 h] | 3,967.43 | 3,864.02 | 2451.4 | 3864.01925 | ELOUADRHIRI L | 1 | 1 | H | LATIFA E | 10-016 | 11-026 | 11 -035 |  | 12-007 |  |  |  |  |  | 12-054 |  |  |  |  |  |  |  |  |  |  |  |  |  |  |
| 142241600 | Assembly of the composite carbon cone - Lab | 10d | 2013-05-06 A | 2013-08-30 A | 9-130M | 100% |  | 2013-11-18 | 2013-12-03 |  |  |  | MECH TECH [80 h] | 3,785.6 | 3,668.8 | 1834.4 | 0 | ELOUADRHIRI L | 1 | 1 | H | LATIFA E | 10-016 | 11-026 | 11 -035 |  | 12-007 |  |  |  |  |  | 12-054 |  |  |  |  |  |  |  |  |  |  |  |  |  |  |
| 142241400 | Tests for coated substrates - Lab FY11 | 69d | 2013-08-30 A | 2013-08-30 A | 142241385a FS-450d, 9-120M FS+80d, 142241385 FS-450d | 100% |  | 2013-09-03 | 2013-12-10 |  |  |  | MECH TECH [23.73 h]; PD UNIV STUDNT [94.9 h]; CONTRB UNIV LBR [213.53 h]; SCIENTIST [23.73 h] | 3,949.36 | 3,862.08 | 3627.161 | 3627.161 | ELOUADRHIRI L | 1 | 1 | U | LATIFA E | 10-016 | 11-026 | 11 -035 | 12-001 | 12-007 |  |  |  |  |  |  |  |  |  |  |  |  |  |  |  |  |  |  |  |  |
| 142241400a | Tests for coated substrates - Lab FY12 | 142d | 2013-08-30 A | 2013-08-30 A | 142241400 | 100% |  | 2013-12-11 | 2014-07-10 |  |  |  | MECH TECH [16.27 h]; PD UNIV STUDNT [65.1 h]; CONTRB UNIV LBR [146.47 h]; SCIENTIST [16.27 h] | 2,732.62 | 2,648.32 | 2566.4805 | 2566.4805 | ELOUADRHIRI L | 1 | 1 | U | LATIFA E | 10-016 | 11-026 | 11 -035 | 12-001 | 12-007 |  |  |  |  |  |  |  |  |  |  |  |  |  |  |  |  |  |  |  |  |
| 142241405 | Dry Fit of Preformed Mirror facets into sectors - Lab FY11 | 21d | 2013-08-30 A | 2013-08-30 A | 142241285, 142241355, 142241290 FS+15d, 142241295 | 100% |  | 2013-09-03 | 2013-10-01 |  |  |  | VISTNG USERS [478.46 h]; SCIENTIST [139.55 h]; MECH DES [15.95 h]; MECH TECH [382.77 h] | 38,117.41 | 38,059.59 | 35741.4122 | 35741.4122 | ELOUADRHIRI L | 1 | 1 | U | LATIFA E | 10-016 | 11-026 | 11 -035 | 12-001 | 12-007 |  |  |  |  |  |  |  |  |  |  |  |  |  |  |  |  |  |  |  |  |
| 142241405a | Dry Fit of Preformed Mirror facets into sectors - Lab FY12 | 21d | 2013-08-30 A | 2013-08-30 A | 142241405 FS-21d | 100% |  | 2013-09-03 | 2013-10-01 |  |  |  | MECH DES [2.7 h]; MECH TECH [64.82 h]; VISTNG USERS [81.03 h]; SCIENTIST [23.63 h] | 6,454.88 | 6,445.1 | 6245.65688 | 6245.65688 | ELOUADRHIRI L | 1 | 1 | U | LATIFA E | 10-016 | 11-026 | 11 -035 | 12-001 | 12-007 |  |  |  |  |  |  |  |  |  |  |  |  |  |  |  |  |  |  |  |  |
| 142241405b | Assembly of the mirror with rings - Lab FY12 | 32d | 2013-08-30 A | 2013-08-30 A | 142241300b, 142241405a | 100% |  | 2013-10-02 | 2013-11-14 |  |  |  | SCIENTIST [128.78 h]; MECH TECH [820.69 h]; VISTNG USERS [193.26 h]; MECH ENG [24.14 h]; MECH DES [6.44 h] | 54,628.85 | 52,942.19 | 51303.2468 | 51303.2468 | ELOUADRHIRI L | 1 | 1 | S | LATIFA E | 10-016 | 11-026 | 11 -035 | 12-001 | 12-007 |  |  |  |  |  |  |  | 12-053 | ST |  |  |  |  |  |  |  |  |  |  |  |
| 142241405ba | Assembly of the mirror with rings - Lab FY13 | 160d | 2013-08-30 A | 2013-08-30 A | 142241405b | 100% |  | 2013-11-15 | 2014-07-14 |  |  |  | SCIENTIST [298.02 h]; MECH DES [14.91 h]; MECH TECH [1899.31 h]; VISTNG USERS [447.25 h]; MECH ENG [55.86 h] | 126,425.32 | 122,521.95 | 122521.936619 | 114959.043848 | ELOUADRHIRI L | 1 | 1 | S | LATIFA E | 10-016 | 11-026 | 11 -035 | 12-001 | 12-007 |  |  |  |  |  |  |  | 12-053 | ST |  |  |  |  |  |  |  |  |  |  |  |
| 142241410 | Quality control of assembled mirror sectors- Lab FY11 | 81d | 2013-08-30 A | 2013-08-30 A | 142241405a, 9-120M FS+80d | 100% |  | 2013-10-02 | 2014-02-04 |  |  |  | SCIENTIST [30.9 h]; MECH ENG [12.36 h]; PD UNIV STUDNT [24.72 h]; CONTRB UNIV LBR [24.72 h] | 3,526.8 | 3,417.91 | 3209.9538 | 3209.9538 | ELOUADRHIRI L | 1 | 1 | U | LATIFA E | 10-016 | 11-026 | 11 -035 | 12-001 | 12-007 |  |  |  |  |  |  |  |  |  |  |  |  |  |  |  |  |  |  |  |  |
| 142241410a | Quality control of assembled mirror sectors - Lab FY12 | 21d | 2013-08-30 A | 2013-08-30 A | 142241410 | 100% |  | 2014-02-05 | 2014-03-06 |  |  |  | MECH ENG [2.79 h]; PD UNIV STUDNT [5.58 h]; CONTRB UNIV LBR [5.58 h]; SCIENTIST [6.98 h] | 796.48 | 771.88 | 747.85685 | 747.85685 | ELOUADRHIRI L | 1 | 1 | U | LATIFA E | 10-016 | 11-026 | 11 -035 | 12-001 | 12-007 |  |  |  |  |  |  |  |  |  |  |  |  |  |  |  |  |  |  |  |  |
| 142241415 | Checks of geometry of mirror sectors - Lab FY11 | 59d | 2013-08-30 A | 2013-08-30 A | 142241405a, 9-120M FS+80d | 100% |  | 2013-10-02 | 2014-01-02 |  |  |  | CONTRB UNIV LBR [23.03 h]; SCIENTIST [46.07 h]; PD UNIV STUDNT [23.03 h] | 3,725.16 | 3,610.22 | 3390.7003 | 3390.7003 | ELOUADRHIRI L | 1 | 1 | U | LATIFA E | 10-016 | 11-026 | 11 -035 | 12-001 | 12-007 |  |  |  |  |  |  |  |  |  |  |  |  |  |  |  |  |  |  |  |  |
| 142241415a | Checks of geometry of mirror rings - Lab FY12 | 21d | 2013-08-30 A | 2013-08-30 A | 142241415 | 100% |  | 2014-01-03 | 2014-02-03 |  |  |  | SCIENTIST [10.4 h]; PD UNIV STUDNT [5.2 h]; CONTRB UNIV LBR [5.2 h] | 840.94 | 814.99 | 789.795802 | 789.795802 | ELOUADRHIRI L | 1 | 1 | U | LATIFA E | 10-016 | 11-026 | 11 -035 | 12-001 | 12-007 |  |  |  |  |  |  |  |  |  |  |  |  |  |  |  |  |  |  |  |  |
| 142241460 | Test of the CV on structural stability - Lab | 45d | 2013-08-30 A | 2013-08-30 A | 142241455 FS-45d | 100% |  | 2014-04-11 | 2014-06-13 |  |  |  | MECH DES [17.78 h]; MECH ENG [17.78 h]; SCIENTIST [17.78 h] | 3,575.77 | 3,465.21 | 7797.2 | 3465.205699 | ELOUADRHIRI L | 1 | 1 | H | LATIFA E | 10-016 | 11-026 | 11 -035 |  | 12-007 |  |  |  |  |  | 12-054 |  |  |  |  |  |  |  |  |  |  |  |  |  |  |
| 142241585 | Assembly of the photo tube housing unit (PMT, HV divider, Winston Cone, Magnetic Shield) - Lab | 63d | 2013-08-30 A | 2013-08-30 A | 142241525 FS-95d, 142241520 FS-95d, 142241510 FS-95d, 142241460 FS-196d, 142241210, 142241475a, 142241500 FS-95d, 142241515 FS-95d, 142241505 FS-95d, 142241490 FS-42d | 100% |  | 2013-09-03 | 2013-12-02 |  |  |  | MECH TECH [80 h]; ELEC TECH [20 h]; VISTNG USERS [60 h] | 5,902.32 | 5,776.6 | 5776.6 | 5776.6 | ELOUADRHIRI L | 1 | 1 | U | LATIFA E | 10-016 | 11-026 | 11 -035 |  | 12-007 |  |  |  |  |  | 12-054 |  |  |  |  |  |  |  |  |  |  |  |  |  |  |
| 142241590 | Installation of 48 housing units - Lab | 80d | 2013-08-30 A | 2013-08-30 A | 142241450b FS-55d, 142241585 | 100% |  | 2014-03-28 | 2014-07-21 |  |  |  | MECH TECH [76 h] | 3,596.32 | 3,485.36 | 3668.8 | 3485.36 | ELOUADRHIRI L | 1 | 1 | U | LATIFA E | 10-016 | 11-026 | 11 -035 |  | 12-007 |  |  |  |  |  | 12-054 |  |  |  |  |  |  |  |  |  |  |  |  |  |  |
| 142241595 | Quality control of the housing unit assembly and installation - Lab | 80d | 2013-08-30 A | 2013-08-30 A | 142241585, 142241590 FS-80d | 100% |  | 2014-03-28 | 2014-07-21 |  |  |  | SCIENTIST [19 h] | 1,428.42 | 1,384.34 | 1457.2 | 1384.34 | ELOUADRHIRI L | 1 | 1 | H | LATIFA E | 10-016 | 11-026 | 11 -035 |  | 12-007 |  |  |  |  |  | 12-054 |  |  |  |  |  |  |  |  |  |  |  |  |  |  |
| 142241647b | Assembly of optical components and reference detectors in the Aluminum box | 260d | 2013-08-30 A | 2013-08-30 A | 142241647a FS+2d | 100% |  | 2013-09-19 | 2014-10-06 |  |  |  | PD UNIV STAFF [20.71 h]; PD UNIV STUDNT [54.37 h] | 1,855.04 | 1,799.46 | 3834.758619 | 1799.460477 | ELOUADRHIRI L | 1 | 1 | H | LATIFA E | 10-016 | 11-026 | 11 -035 |  | 12-007 |  |  |  |  | 12-027 |  |  |  |  |  |  |  |  |  |  |  |  |  |  |  |
| 142241647c | Tests of optical components and reference detectors in the Aluminum box | 263d | 2013-08-30 A | 2013-08-30 A | 142241647b FS-257d | 100% |  | 2013-09-24 | 2014-10-14 |  |  |  | PD UNIV STAFF [12.07 h]; PD UNIV STUDNT [24.13 h] | 995.51 | 965.34 | 2133.333349 | 965.333349 | ELOUADRHIRI L | 1 | 1 | H | LATIFA E | 10-016 | 11-026 | 11 -035 |  | 12-007 |  |  |  |  | 12-027 |  |  |  |  |  |  |  |  |  |  |  |  |  |  |  |
| 142241655 | Re-Baseline Actuals Adjustment | 1d | 2013-08-30 A | 2013-08-30 A |  | 100% |  | 2013-09-03 | 2013-09-03 |  |  |  | PROCUREMENT>$50K 69 NO ESCALATION | 452,568.48 |  |  | 452568.48 |  |  |  |  |  |  |  |  |  |  | 0 | 452568.48 | 45256848 | 100 |  |  |  |  |  | ADJ |  |  |  |  |  |  |  |  |  |  |
| 242241370 | Assembly, tests and QA of additional substrates (up to 10 substrates total) FY13 | 42d | 2013-09-03 A | 2013-09-23 A | 9-130M FS+228d | 100% |  | 2013-10-01 | 2013-11-27 |  |  | 8/5 M-F w/JLAB Holidays ReBaseline | VISTNG USERS [5.71 h]; MECH TECH [5.71 h] | 388.1 | 376.1 |  | 0 | ELOUADRHIRI L | 1 | 1 | U | LATIFA E | 10-016 | 11-026 | 11 -035 | 12-001 | 12-007 |  |  |  |  |  |  |  |  |  |  | 242241370 | 376.10415 | 13-002F | PE | 13-015 | PR |  |  |  |  |
| 242241370a | Assembly, tests and QA of additional substrates (up to 10 substrates total) FY14 | 9.5d | 2013-09-03 A | 2013-09-23 A | 242241370 | 100% |  | 2013-10-01 | 2013-10-14 |  |  | 8/5 M-F w/JLAB Holidays ReBaseline | VISTNG USERS [6.29 h]; MECH TECH [6.29 h] | 426.82 | 413.62 |  | 0 | ELOUADRHIRI L | 1 | 1 | U | LATIFA E | 10-016 | 11-026 | 11 -035 | 12-001 | 12-007 |  |  |  |  |  |  |  |  |  |  | 242241370 | 426.81435 | 13-002F | PE | 13-015 | PR | 14-001 |  |  |  |
| 242241372 | Precision trimming of additional substrates (up to 10 substrates total) - Labor/Expenses FY13 | 62d | 2013-09-03 A | 2013-10-21 A | 9-130M FS+228d | 100% |  | 2013-10-01 | 2014-01-08 |  |  | 8/5 M-F w/JLAB Holidays ReBaseline | VISTNG USERS [6.45 h]; SUPPLIES & MATERIALS | 939.26 | 132.11 |  | 467.56375 | ELOUADRHIRI L | 1 | 1 | D | LATIFA E | 10-016 | 11-026 | 11 -035 | 12-001 | 12-007 |  |  |  |  |  |  |  |  |  |  | 242241372 | 467.56375 | 13-002F | PE | 13-015 | PR |  | EJ |  |  |
| 242241372a | Precision trimming of additional substrates (up to 10 substrates total) - Labor/Expenses FY14 | 42d | 2013-09-03 A | 2013-10-21 A | 242241372 FS-50d | 100% |  | 2013-10-01 | 2013-11-27 |  |  | 8/5 M-F w/JLAB Holidays ReBaseline | VISTNG USERS [13.55 h]; SUPPLIES & MATERIALS | 2,026.56 | 276.95 |  | 1013.28225 | ELOUADRHIRI L | 1 | 1 | D | LATIFA E | 10-016 | 11-026 | 11 -035 | 12-001 | 12-007 |  |  |  |  |  |  |  |  |  |  | 242241372 | 1013.28225 | 13-002F | PE | 13-015 | PR | 14-001 | EJ |  |  |
| 242241390 | Coating of 60 substrates with Al + MgF2 - Proc | 72d | 2013-09-03 A | 2013-12-13 | 9-130M FS+228d |  | 29d | 2013-10-01 | 2014-01-23 | 180d | 21d | 8/5 M-F w/JLAB Holidays ReBaseline | PROCUREMENT<$50K 60 NO ESCALATION FY14 | 13,250 |  |  | 0 | ELOUADRHIRI L | 1 | 1 | U | LATIFA E | 10-016 | 11-026 | 11 -035 |  | 12-007 | 13250 | 0 | 0 | 100 |  | 12-054 |  |  |  |  | 242241390 |  | 13-002F |  | 13-015 | PR |  |  | OB | OB |
| 242241400 | UCONN Quality control of 60 coated substrates - Lab | 234d | 2013-09-03 A | 2014-08-13 | 242241390 FS-72d | 2% | 191d | 2013-10-01 | 2014-09-11 | 159d | 34d | 8/5 M-F w/JLAB Holidays ReBaseline | PROCUREMENT<$50K 60 NO ESCALATION FY14 | 2,136 |  |  | 0 | ELOUADRHIRI L | 1 | 1 | U | LATIFA E | 10-016 | 11-026 | 11 -035 | 12-001 | 12-007 | 2093.28 | 42.72 | 4272 | 100 |  |  |  |  |  |  | 242241395 | 42.72 | 13-002F | PE | 13-015 | PR |  |  | OB | OB |
| 242241450aa | Manufacturing of top level assembly parts of the CV construction FY13 | 20d | 2013-09-03 A | 2013-10-21 A | 9-130M FS+228d | 100% |  | 2013-10-01 | 2013-10-28 |  |  | 8/5 M-F w/JLAB Holidays ReBaseline | SUPPLIES & MATERIALS | 5,555.56 |  |  | 5555.56 | ELOUADRHIRI L | 1 | 1 | D | LATIFA E | 10-016 | 11-026 | 11 -035 | 12-001 | 12-007 |  |  |  |  |  | 12-054 |  |  |  |  | 242241450aa |  | 13-002F | PE | 13-015 | PR |  | PE |  |  |
| 242241450aaa | Manufacturing of top level assembly parts of the CV construction FY14 | 34d | 2013-09-03 A | 2013-10-21 A | 242241450aa FS-40d | 100% |  | 2013-10-29 | 2013-12-17 |  |  | 8/5 M-F w/JLAB Holidays ReBaseline | SUPPLIES & MATERIALS | 9,745.72 |  |  | 9745.72 | ELOUADRHIRI L | 1 | 1 | D | LATIFA E | 10-016 | 11-026 | 11 -035 | 12-001 | 12-007 |  |  |  |  |  | 12-054 |  |  |  |  | 242241450aa |  | 13-002F | PE | 13-015 | PR | 14-001 | PE |  |  |
| 242241450b | Assembly of the CV FY13 | 20d | 2013-09-03 A | 2014-03-18 | 242241450aa FS-45d, 242241450aaa FS-45d, 9-130M FS+228d |  | 87d | 2013-10-01 | 2013-10-28 | 237d | 13d | 8/5 M-F w/JLAB Holidays ReBaseline | MECH TECH [118.46 h] | 5,605.53 | 1,827.53 |  | 0 | ELOUADRHIRI L | 1 | 1 | S | LATIFA E | 10-016 | 11-026 | 11 -035 | 12-001 | 12-007 |  |  |  |  |  | 12-054 |  |  | ST |  | 242241450b |  | 13-002F | PE | 13-015 | PR |  |  |  |  |
| 242241450ba | Assembly of the CV FY14 | 110d | 2013-09-03 A | 2014-03-18 | 242241450b FS-140d, 242241450aaa FS-70d |  | 87d | 2013-10-29 | 2014-04-15 | 237d | 13d | 8/5 M-F w/JLAB Holidays ReBaseline | MECH TECH [651.54 h] | 30,830.87 | 10,051.56 |  | 0 | ELOUADRHIRI L | 1 | 1 | S | LATIFA E | 10-016 | 11-026 | 11 -035 | 12-001 | 12-007 |  |  |  |  |  | 12-054 |  |  | ST |  | 242241450b |  | 13-002F | PE | 13-015 | PR | 14-001 |  |  |  |
| 242241452 | Vend Fab HTCC Support Cart | 20d | 2013-09-03 A | 2013-09-23 A | 9-130M FS+228d | 100% |  | 2013-10-01 | 2013-10-28 |  |  | 8/5 M-F w/JLAB Holidays ReBaseline | PROCUREMENT<$50K 60 | 16,272.97 |  |  | 0 | ELOUADRHIRI L | 1 | 1 | D | LATIFA E | 10-016 | 11-026 | 11 -035 | 12-001 | 12-007 | 0 | 16272.97 | 1627297 | 100 |  | 12-054 |  |  |  |  | 242241580 | 16272.97 | 13-002F |  | 13-015 | PR |  | PE | PE | OB |
| 242241457 | HTCC Winston Cone Fabricate finals | 20d | 2013-09-03 A | 2013-09-23 A | 9-130M FS+228d | 100% |  | 2013-10-01 | 2013-10-28 |  |  | 8/5 M-F w/JLAB Holidays ReBaseline | PROCUREMENT<$50K 60 | 3,300 |  |  | 0 | ELOUADRHIRI L | 1 | 1 | D | LATIFA E | 10-016 | 11-026 | 11 -035 | 12-001 | 12-007 | 0 | 3300 | 330000 | 100 |  | 12-054 |  |  |  |  | 242241580 | 3300 | 13-002F |  | 13-015 | PR |  | PE | PE | OB |
| 242241462 | HTCC Consumables | 20d | 2013-09-03 A | 2013-09-23 A | 9-130M FS+228d | 100% |  | 2013-10-01 | 2013-10-28 |  |  | 8/5 M-F w/JLAB Holidays ReBaseline | PROCUREMENT<$50K 60 | 304.92 |  |  | 0 | ELOUADRHIRI L | 1 | 1 | D | LATIFA E | 10-016 | 11-026 | 11 -035 | 12-001 | 12-007 | 0 | 304.92 | 30492 | 100 |  | 12-054 |  |  |  |  | 242241580 | 304.92 | 13-002F |  | 13-015 | PR |  | PE | PE | OB |
| 242241395 | Quality control of 60 coated substrates - Proc | 128d | 2013-10-01 A | 2013-10-21 A | 242241390 FS-50d | 100% |  | 2013-11-01 | 2014-05-14 |  |  | 8/5 M-F w/JLAB Holidays ReBaseline | PROCUREMENT<$50K 60 | 9,036.97 |  |  | 9036.97 | ELOUADRHIRI L | 1 | 1 | U | LATIFA E | 10-016 | 11-026 | 11 -035 | 12-001 | 12-007 | 0 | 9036.97 | 903697 | 100 |  |  |  |  |  |  | 242241395 |  | 13-002F | PE | 13-015 | PR | 14-001 |  | OB | OB-2 |
| 242241395a | Quality control of 60 coated substrates - Lab | 212d | 2013-10-01 A | 2014-08-13 | 242241390 FS-50d |  | 191d | 2013-11-01 | 2014-09-12 | 159d | 34d | 8/5 M-F w/JLAB Holidays ReBaseline | PD UNIV STUDNT [110.16 h]; MECH TECH [27.54 h]; PD UNIV STAFF [59.84 h]; SCIENTIST [45.22 h] | 9,534.48 | 1,024.73 |  | 0 | ELOUADRHIRI L | 1 | 1 | U | LATIFA E | 10-016 | 11-026 | 11 -035 | 12-001 | 12-007 |  |  |  |  |  |  |  |  |  |  | 242241395a |  | 13-002F | PE | 13-015 | PR | 14-001 |  |  |  |
| 242241300 | Tooling manufacturing for Quality Control of combined mirror assembly | 85d | 2013-11-01 | 2014-03-14 | 9-140M FS+23d |  |  |  |  | 265d | 140d | 8/5 M-F w/JLAB Holidays ReBaseline | MSHOP | 25,797.5 |  |  | 0 | ELOUADRHIRI L | 1 | 1 | U | LATIFA E | 10-016 | 11-026 | 11 -035 |  | 12-007 |  |  |  |  |  |  |  |  |  |  | 242241300 |  | 13-002F |  | 13-015 | PR | 14-001 | EJ |  |  |
| 242241405 | Dry Fit of Preformed Mirror facets into rings - Lab | 157d | 2013-11-01 | 2014-06-25 | 9-140M FS+23d |  |  |  |  | 159d | 0d | 8/5 M-F w/JLAB Holidays ReBaseline | SCIENTIST [160 h]; MECH DES [40 h]; MECH TECH [480 h]; VISTNG USERS [560 h] | 48,324.8 |  |  | 0 | ELOUADRHIRI L | 1 | 1 | S | LATIFA E | 10-016 | 11-026 | 11 -035 | 12-001 | 12-007 |  |  |  |  |  |  |  |  |  |  | 242241405 |  | 13-002F | PE | 13-015 | PR | 14-001 |  |  |  |
| 242241415 | Checks of geometry of mirror half-sectors - Expenses FY13 | 20d | 2013-11-01 | 2013-12-02 | 9-140M FS+23d, 9-130M FS+228d |  |  |  |  | 125d | 0d | 8/5 M-F w/JLAB Holidays ReBaseline | SUPPLIES & MATERIALS | 49.26 |  |  | 0 | ELOUADRHIRI L | 1 | 1 | H | LATIFA E | 10-016 | 11-026 | 11 -035 | 12-001 | 12-007 |  |  |  |  |  |  |  |  |  |  | 242241415 |  | 13-002F |  | 13-015 | PR |  | EJ |  |  |
| 242241455 | Quality control fo the CV construction - Lab FY13 | 10d | 2013-11-01 | 2013-11-14 | 242241450b FS-100d, 242241450ba FS-100d |  |  |  |  | 224d | 0d | 8/5 M-F w/JLAB Holidays ReBaseline | MECH TECH [11.51 h]; SCIENTIST [5.76 h] | 977.6 |  |  | 0 | ELOUADRHIRI L | 1 | 1 | S | LATIFA E | 10-016 | 11-026 | 11 -035 |  | 12-007 |  |  |  |  |  | 12-054 |  |  |  |  | 242241455 |  | 13-002F | PE | 13-015 | PR |  |  |  |  |
| 242241580 | Procurement of miscellaneous parts - Proc | 64d | 2013-11-01 | 2014-02-13 | 9-130M FS+228d, 9-140M FS+23d |  |  |  |  | 157d | 43d | 8/5 M-F w/JLAB Holidays ReBaseline | SUPPLIES & MATERIALS; PROCUREMENT<$50K 60 NO ESCALATION FY14 | 5,775 |  |  | 0 | ELOUADRHIRI L | 1 | 1 | D | LATIFA E | 10-016 | 11-026 | 11 -035 | 12-001 | 12-007 | 5775 | 0 | 0 | 100 |  | 12-054 |  |  |  |  | 242241580 |  | 13-002F |  | 13-015 | PR |  | PE | PE |  |
| 242241580a | Procurement of miscellaneous parts - Expenses FY13 | 20d | 2013-11-01 | 2013-12-02 | 9-140M FS+23d |  |  |  |  | 114d | 0d | 8/5 M-F w/JLAB Holidays ReBaseline | SUPPLIES & MATERIALS | 1,308.41 |  |  | 0 | ELOUADRHIRI L | 1 | 1 | D | LATIFA E | 10-016 | 11-026 | 11 -035 | 12-001 | 12-007 |  |  |  |  |  | 12-054 |  |  |  |  | 242241580 |  | 13-002F |  | 13-015 | PR |  | PE | PE |  |
| 242241647a | Proc of components for the HTCC Light Monitoring System | 172d | 2013-11-01 | 2014-07-17 | 9-140M FS+23d |  |  |  |  | 274d | 160d | 8/5 M-F w/JLAB Holidays ReBaseline | PROCUREMENT<$50K 60 | 2,966.71 |  |  | 0 | ELOUADRHIRI L | 1 | 1 | D | LATIFA E | 10-016 | 11-026 | 11 -035 |  | 12-007 | 2966.71 | 0 | 0 | 100 | 12-027 |  |  |  |  |  | 242241647a |  | 13-002F |  | 13-015 | PR | 14-001 |  | EV |  |

Notes:
- 142241450b: Steps: Assembly of the CV - Lab Revised (done)
- 142241405b: Steps: Assembly of the mirror with rings - Lab FY12 (done)
- 142241405ba: Steps: Assembly of the mirror with rings - Lab FY13 (done)
- 242241450b: Steps: Completion of the assembly major structural members of the CV; Attachment of the outer shells of the CV; Powerwash and painting of the CV; Placement of the cleaned/painted CV inside of the clean room
- 242241450ba: Steps: Completion of the assembly major structural members of the CV; Attachment of the outer shells of the CV; Powerwash and painting of the CV; Placement of the cleaned/painted CV inside of the clean room

| ID | WBS | Activity | Type | Duration | Start | Finish | Predecessors | Complete | Planned start | Planned finish | Total float | Free float | Calendar | Resources | Cost | Actual cost | Original Activity ID Rebaseline | MONTHLY EV COST | RESP - Responsibility | STRT%COMP for CM EVM | FNSH%COMP for CM EVM | EVMS Reporting Codes | CAM RESPONSIBLE | CR 10-016 | CR 11-026 | CR 11-035 | CR 12-007 | CR 12-054 | CR 13-002 | BOE Labor | CR 13-015 | Post Rebaseline | CR 14-001 | CR 12-001 | BOE Expenses | BOE Procurement | Remaining Material Cost Based on % Compl | Claimed Material Cost Based on % Complet | Initial Claimed Material Calc | Claimed Material Divider | Activities with Steps | CR 12-053 | CR 12-027 | Calculated Remaining Total Cost | PHAS - Project Phase | Advance Purchase Plan > 500K | CR 08-016 | CR 09-012 | CR 09-030 Repair | MARCH!!! |
| --- | --- | --- | --- | --- | --- | --- | --- | --- | --- | --- | --- | --- | --- | --- | --- | --- | --- | --- | --- | --- | --- | --- | --- | --- | --- | --- | --- | --- | --- | --- | --- | --- | --- | --- | --- | --- | --- | --- | --- | --- | --- | --- | --- | --- | --- | --- | --- | --- | --- | --- |
| 242241455a |  | Quality control fo the CV construction - Lab FY14 |  | 129d | 2013-11-15 | 2014-05-30 | 242241455, 242241450ba FS-120d |  |  |  | 224d | 0d | 8/5 M-F w/JLAB Holidays ReBaseline | MECH TECH [148.49 h]; SCIENTIST [74.24 h] | 12,608 |  | 242241455 | 0 | ELOUADRHIRI L | 1 | 1 | S | LATIFA E | 10-016 | 11-026 | 11 -035 | 12-007 | 12-054 | 13-002F | PE | 13-015 | PR | 14-001 |  |  |  |  |  |  |  |  |  |  |  |  |  |  |  |  |  |
| 242241415a |  | Checks of geometry of mirror half-sectors - Expenses FY14 |  | 183d | 2013-12-03 | 2014-08-29 | 242241415 |  |  |  | 125d | 0d | 8/5 M-F w/JLAB Holidays ReBaseline | SUPPLIES & MATERIALS | 465.12 |  | 242241415 | 0 | ELOUADRHIRI L | 1 | 1 | H | LATIFA E | 10-016 | 11-026 | 11 -035 | 12-007 |  | 13-002F |  | 13-015 | PR | 14-001 | 12-001 | EJ |  |  |  |  |  |  |  |  |  |  |  |  |  |  |  |
| 242241580b |  | Procurement of miscellaneous parts - Expenses FY14 |  | 87d | 2013-12-03 | 2014-04-15 | 242241580a |  |  |  | 114d | 0d | 8/5 M-F w/JLAB Holidays ReBaseline | SUPPLIES & MATERIALS | 5,873.15 |  | 242241580 | 0 | ELOUADRHIRI L | 1 | 1 | D | LATIFA E | 10-016 | 11-026 | 11 -035 | 12-007 | 12-054 | 13-002F |  | 13-015 | PR | 14-001 | 12-001 | PE | PE |  |  |  |  |  |  |  |  |  |  |  |  |  |  |
| 242241430 |  | Procurement of HEPA filters for the HTCC Clean Room |  | 290d | 2014-02-03 | 2015-04-02 | 9-140M FS+80d |  |  |  | 168d | 54d | 8/5 M-F w/JLAB Holidays ReBaseline | PROCUREMENT<$50K 60 NO ESCALATION FY15 | 5,572.26 |  | 242241430 | 0 | ELOUADRHIRI L | 1 | 1 | U | LATIFA E | 10-016 | 11-026 | 11 -035 | 12-007 |  | 13-002F |  | 13-015 | PR | 14-001 |  |  | PE | 5572.26 | 0 | 0 | 100 |  |  |  |  |  |  |  |  |  |  |
| 242241435 |  | Change Out of HEPA filters for the HTCC Clean Room |  | 291d | 2014-02-03 | 2015-04-03 | 9-140M FS+80d |  |  |  | 167d | 53d | 8/5 M-F w/JLAB Holidays ReBaseline | MECH TECH [48 h] | 2,271.36 |  | 242241435 | 0 | ELOUADRHIRI L | 1 | 1 | U | LATIFA E | 10-016 | 11-026 | 11 -035 | 12-007 |  | 13-002F | PE | 13-015 | PR | 14-001 |  |  |  |  |  |  |  |  |  |  |  |  |  |  |  |  |  |
| 242241405b |  | Assembly of the mirror with rings - Lab |  | 150d | 2014-02-05 | 2014-09-05 | 242241405 FS-100d |  |  |  | 159d | 34d | 8/5 M-F w/JLAB Holidays ReBaseline | MECH DES [60 h]; MECH TECH [2340 h]; MECH ENG [60 h] | 118,287 |  | 242241405b | 0 | ELOUADRHIRI L | 1 | 1 | S | LATIFA E | 10-016 | 11-026 | 11 -035 | 12-007 |  | 13-002F | PE | 13-015 | PR | 14-001 | 12-001 |  |  |  |  |  |  | ST | 12-053 |  |  |  |  |  |  |  |  |
| 242241410 |  | Quality control of assembled mirror half-sectors - Lab |  | 150d | 2014-02-05 | 2014-09-05 | 242241405 FS-100d |  |  |  | 159d | 34d | 8/5 M-F w/JLAB Holidays ReBaseline | PD UNIV STAFF [80 h]; MECH ENG [80 h]; PD UNIV STUDNT [1280 h]; SCIENTIST [640 h] | 73,416 |  | 242241410 | 0 | ELOUADRHIRI L | 1 | 1 | S | LATIFA E | 10-016 | 11-026 | 11 -035 | 12-007 |  | 13-002F | PE | 13-015 | PR | 14-001 | 12-001 |  |  |  |  |  |  | ST |  |  |  |  |  |  |  |  |  |
| 242241528 |  | Assembly of the HTCC Gas System |  | 65d | 2014-03-03 | 2014-06-02 | 9-140M FS+99d |  |  |  | 373d | 259d | 8/5 M-F w/JLAB Holidays ReBaseline | ELEC TECH [80 h]; VISTNG USERS [120 h]; SCIENTIST [20 h]; MECH TECH [80 h] | 11,519.2 |  | 242241528 | 0 | ELOUADRHIRI L | 1 | 1 | S | LATIFA E | 10-016 | 11-026 | 11 -035 | 12-007 |  | 13-002F | PE | 13-015 | PR | 14-001 |  |  |  |  |  |  |  |  |  |  |  |  |  |  |  |  |  |
| 242241600 |  | Assembly of the composite carbon cone - Lab |  | 20d | 2014-04-03 | 2014-04-30 | 242241455a FS-41d, 242241455 FS-41d |  |  |  | 268d | 0d | 8/5 M-F w/JLAB Holidays ReBaseline | MECH TECH [80 h] | 3,785.6 |  | 242241600 | 0 | ELOUADRHIRI L | 1 | 1 | H | LATIFA E | 10-016 | 11-026 | 11 -035 | 12-007 | 12-054 | 13-002F | PE | 13-015 | PR | 14-001 |  |  |  |  |  |  |  |  |  |  |  |  |  |  |  |  |  |
| 242241585 |  | Assembly of the photo tube housing unit (PMT, HV divider, Winston Cone, Magnetic Shield) - Lab |  | 163d | 2014-04-16 | 2014-12-05 | 242241580, 242241455a FS-260d, 242241580b, 242241455 FS-260d |  |  |  | 114d | 0d | 8/5 M-F w/JLAB Holidays ReBaseline | SCIENTIST [10 h]; MECH TECH [80 h]; ELEC TECH [20 h]; VISTNG USERS [240 h] | 10,418.8 |  | 242241585 | 0 | ELOUADRHIRI L | 1 | 1 | S | LATIFA E | 10-016 | 11-026 | 11 -035 | 12-007 | 12-054 | 13-002F | PE | 13-015 | PR | 14-001 |  |  |  |  |  |  |  |  |  |  |  |  |  |  |  |  |  |
| 242241605 |  | Installation of the assembled carbon cone - Lab |  | 107d | 2014-05-30 | 2014-10-29 | 242241600 FS+20d |  |  |  | 268d | 154d | 8/5 M-F w/JLAB Holidays ReBaseline | MECH TECH [80 h]; MECH ENG [20 h]; SCIENTIST [20 h] | 6,782.6 |  | 242241605 | 0 | ELOUADRHIRI L | 1 | 1 | S | LATIFA E | 10-016 | 11-026 | 11 -035 | 12-007 | 12-054 | 13-002F | PE | 13-015 | PR | 14-001 |  |  |  |  |  |  |  | ST |  |  |  |  |  |  |  |  |  |
| 242241610 |  | Installation of the composite exit window - Lab |  | 107d | 2014-05-30 | 2014-10-29 | 242241455 FS-1d, 242241455a FS-1d |  |  |  | 268d | 154d | 8/5 M-F w/JLAB Holidays ReBaseline | MECH TECH [80 h] | 3,785.6 |  | 242241610 | 0 | ELOUADRHIRI L | 1 | 1 | S | LATIFA E | 10-016 | 11-026 | 11 -035 | 12-007 | 12-054 | 13-002F | PE | 13-015 | PR | 14-001 |  |  |  |  |  |  |  | ST |  |  |  |  |  |  |  |  |  |
| 242241630 |  | Installation of a temporary CO2 gas supply system - Lab |  | 44d | 2014-06-16 | 2014-08-15 | 9-140M FS+173d |  |  |  | 320d | 206d | 8/5 M-F w/JLAB Holidays ReBaseline | MECH TECH [140 h] | 6,624.8 |  | 242241630 | 0 | ELOUADRHIRI L | 1 | 1 | H | LATIFA E | 10-016 | 11-026 | 11 -035 | 12-007 | 12-054 | 13-002F | PE | 13-015 | PR | 14-001 |  |  |  |  |  |  |  |  |  |  |  |  |  |  |  |  |  |
| 242241417 |  | Manufacturing of modified HV-dividers for the 5" PMTs (50 units)-Lab |  | 62d | 2014-07-07 | 2014-10-01 | 242241415 FS-40d, 242241415a FS-40d |  |  |  | 125d | 0d | 8/5 M-F w/JLAB Holidays ReBaseline | ELEC TECH [40 h] | 1,879.6 |  | 242241417 | 0 | ELOUADRHIRI L | 1 | 1 | H | LATIFA E | 10-016 | 11-026 | 11 -035 | 12-007 |  | 13-002F | PE | 13-015 | PR | 14-001 | 12-001 |  |  |  |  |  |  |  |  |  |  |  |  |  |  |  |  |
| 242241425 |  | Quality control of the final mirror assembly - Lab |  | 44d | 2014-10-02 | 2014-12-04 | 242241400, 242241395, 242241417, 242241300, 242241410 FS-16d, 242241395a, 242241405b FS-16d |  |  |  | 125d | 0d | 8/5 M-F w/JLAB Holidays ReBaseline | MECH TECH [352 h]; PD UNIV STAFF [352 h]; SCIENTIST [352 h] | 64,180.16 |  | 242241425 | 0 | ELOUADRHIRI L | 1 | 1 | S | LATIFA E | 10-016 | 11-026 | 11 -035 | 12-007 |  | 13-002F | PE | 13-015 | PR | 14-001 |  | EJ |  |  |  |  |  |  |  |  |  |  |  |  |  |  |  |
| 242241590 |  | Installation of 48 housing units - Lab |  | 43d | 2014-12-08 | 2015-02-17 | 242241450b FS-55d, 242241455a FS+21d, 242241585, 242241455 FS+21d, 242241450ba FS-55d |  |  |  | 114d | 0d | 8/5 M-F w/JLAB Holidays ReBaseline | SCIENTIST [20 h]; VISTNG USERS [240 h]; MECH TECH [160 h] | 14,016.4 |  | 242241590 | 0 | ELOUADRHIRI L | 1 | 1 | S | LATIFA E | 10-016 | 11-026 | 11 -035 | 12-007 | 12-054 | 13-002F | PE | 13-015 | PR | 14-001 |  |  |  |  |  |  |  |  |  |  |  |  |  |  |  |  |  |
| 242241595 |  | Quality control of the housing unit assembly and installation - Lab |  | 43d | 2014-12-08 | 2015-02-17 | 242241590 FS-43d, 242241585 |  |  |  | 114d | 0d | 8/5 M-F w/JLAB Holidays ReBaseline | VISTNG USERS [40 h]; SCIENTIST [80 h] | 6,838 |  | 242241595 | 0 | ELOUADRHIRI L | 1 | 1 | H | LATIFA E | 10-016 | 11-026 | 11 -035 | 12-007 | 12-054 | 13-002F | PE | 13-015 | PR | 14-001 |  |  |  |  |  |  |  |  |  |  |  |  |  |  |  |  |  |
| 242241647d5 |  | Quality control of the installed items |  | 106d | 2015-01-21 | 2015-06-19 | 242241647d FS-62d |  |  |  | 114d | 0d | 8/5 M-F w/JLAB Holidays ReBaseline | SCIENTIST [280 h]; VISTNG USERS [280 h]; PD UNIV STUDNT [222.4 h]; PD UNIV STAFF [97.6 h] | 35,181.47 |  | 242241647d5 | 0 | ELOUADRHIRI L | 1 | 1 | S | LATIFA E | 10-016 | 11-026 | 11 -035 | 12-007 |  | 13-002F | PE | 13-015 | PR | 14-001 |  |  |  |  |  |  |  | ST |  | 12-027 |  |  |  |  |  |  |  |
| 242241647d |  | Installation of LMS |  | 44d | 2015-02-16 | 2015-04-16 | 242241647a FS-21d, 242241595 FS-2d |  |  |  | 114d | 0d | 8/5 M-F w/JLAB Holidays ReBaseline | SCIENTIST [4 h]; VISTNG USERS [80 h]; PD UNIV STUDNT [53.33 h]; PD UNIV STAFF [53.2 h] | 5,736.75 |  | 242241647d | 0 | ELOUADRHIRI L | 1 | 1 | S | LATIFA E | 10-016 | 11-026 | 11 -035 | 12-007 |  | 13-002F | PE | 13-015 | PR | 14-001 |  |  |  |  |  |  |  |  |  | 12-027 |  |  |  |  |  |  |  |
| 242241640 |  | Installation ofthe ellipsoidal mirror - Lab |  | 40d | 2015-03-09 | 2015-05-01 | 242241425 FS+57d |  |  |  | 125d | 0d | 8/5 M-F w/JLAB Holidays ReBaseline | VISTNG USERS [109.47 h]; SCIENTIST [72.98 h]; MECH DES [18.25 h]; MECH TECH [821.05 h]; MECH ENG [18.25 h] | 48,891.49 |  | 242241640 | 0 | ELOUADRHIRI L | 1 | 1 | S | LATIFA E | 10-016 | 11-026 | 11 -035 | 12-007 | 12-054 | 13-002F | PE | 13-015 | PR | 14-001 |  |  |  |  |  |  |  | ST |  |  |  |  |  |  |  |  |  |
| 242241645 |  | Optical tests of mirror geometry in situ - Lab |  | 21d | 2015-05-05 | 2015-06-04 | 242241640 FS+1d |  |  |  | 125d | 11d | 8/5 M-F w/JLAB Holidays ReBaseline | VISTNG USERS [80 h]; PD UNIV STAFF [40 h]; PD UNIV STUDNT [40 h]; SCIENTIST [80 h] | 10,509.2 |  | 242241645 | 0 | ELOUADRHIRI L | 1 | 1 | H | LATIFA E | 10-016 | 11-026 | 11 -035 | 12-007 | 12-054 | 13-002F | PE | 13-015 | PR | 14-001 |  |  |  |  |  |  |  |  |  |  |  |  |  |  |  |  |  |
| 242241650M |  | HTCC Ready for Installation in the Hall | milestone | 0d | 2015-06-19 | 2015-06-19 | 242241595, 242241370, 242241647d5, 242241435, 242241590, 242241372a, 242241430, 242241610, 242241605, 242241372, 242241528, 242241370a, 242241645, 242241630 |  |  |  | 114d | 0d | 8/5 M-F w/JLAB Holidays ReBaseline |  |  |  | 242241650M | 0 | ELOUADRHIRI L | 1 | 1 | M | LATIFA E | 10-016 | 11-026 | 11 -035 | 12-007 |  | 13-002F |  | 13-015 | PR |  |  |  |  |  |  |  |  |  |  | 12-027 |  |  |  |  |  |  |  |
|  | 2 | **1.4.2.2.4.2 LOW THRESHOLD CC** |  |  | 2011-11-01 | 2015-04-24 |  |  |  |  |  |  |  |  |  |  |  |  |  |  |  |  |  |  |  |  |  |  |  |  |  |  |  |  |  |  |  |  |  |  |  |  |  |  |  |  |  |  |  |  |
| 142242120 |  | Build Scale Model of Box |  | 66d | 2011-11-01 A | 2012-02-13 A | 9-120M FS+21d | 100% |  |  |  |  |  | MECH TECH [80 h]; MECH DES [40 h] | 5,482 | 5,482 |  | 5482 | ELOUADRHIRI L | 1 | 1 | H | LATIFA E |  |  |  | 12-007 |  |  |  |  |  |  |  |  |  |  |  |  |  |  |  |  | 0 | IN | APP |  |  |  |  |
| 142242005 |  | Procure Shelving/Desk/Oscilliscope and Computers for LTCC |  | 111d | 2012-01-03 A | 2012-06-11 A | 142242000M FS-40d | 100% |  |  |  |  |  | PROCUREMENT>$50K 69; SCIENTIST [20 h] | 23,912.2 | 1,412.2 |  | 23912.2 | ELOUADRHIRI L | 1 | 1 | D | LATIFA E |  | 11-026 | 11 -035 | 12-007 |  |  |  |  |  |  |  |  |  | 0 | 22500 | 2250000 | 100 |  |  |  | 0 |  | APP |  |  |  |  |
| 142242125 |  | Gas Window Test on Scale Model |  | 132d | 2012-01-09 A | 2012-07-16 A | 142242120 FS-25d | 100% |  |  |  |  |  | MECH TECH [40 h]; MECH DES [20 h]; SCIENTIST [10 h]; VISTNG USERS [10 h] | 3,640.4 | 3,640.4 |  | 3640.4 | ELOUADRHIRI L | 1 | 1 | H | LATIFA E |  |  |  | 12-007 |  |  |  |  |  |  |  |  |  |  |  |  |  |  |  |  | 0 | IN | APP |  |  |  |  |
| 142242035 |  | Final Manufacturing Drawings of Alignment Tool |  | 279d | 2012-01-18 A | 2013-08-30 A | 9-120M FS+68d | 100% | 2012-01-18 | 2013-03-01 |  |  |  | SCIENTIST [36 h]; MECH DES [48 h]; VISTNG USERS [36 h] | 5,613.52 | 5,649.29 |  | 5550 | ELOUADRHIRI L | 1 | 1 | H | LATIFA E |  |  |  | 12-007 |  |  |  |  |  |  |  |  |  |  |  |  |  |  |  |  | 2775 | IN | APP |  |  |  |  |
| 142242130 |  | Gas Window Simulation |  | 300d | 2012-01-18 A | 2013-06-17 A | 142242120 FS-31d | 100% | 2012-01-18 | 2013-04-01 |  |  |  | SCIENTIST [40 h]; VISTNG USERS [40 h] | 3,643.9 | 3,654.35 |  | 3597.6 | ELOUADRHIRI L | 1 | 1 | H | LATIFA E |  |  |  | 12-007 |  |  |  |  |  |  |  |  |  |  |  |  |  |  |  |  | 0 | IN | APP |  |  |  |  |
| 142242140 |  | Box Walls Simulation |  | 300d | 2012-01-18 A | 2013-08-15 A | 142242120 FS-31d | 100% | 2012-01-18 | 2013-04-01 |  |  |  |  |  |  |  | 0 | ELOUADRHIRI L | 1 | 1 | Z | LATIFA E |  |  |  | 12-007 |  |  |  |  |  |  |  |  |  |  |  |  |  |  |  |  |  | IN | APP |  |  |  |  |
| 142242030 |  | Quality Control of PMTs |  | 9d | 2012-02-01 A | 2012-02-14 A | 142242020, 142242015, 142242025 | 100% | 2012-02-01 | 2012-02-13 |  |  |  | SCIENTIST [40 h]; VISTNG USERS [80 h] | 4,370.8 | 4,370.8 |  | 4370.8 | ELOUADRHIRI L | 1 | 1 | H | LATIFA E |  |  |  | 12-007 |  |  |  |  |  |  |  |  |  |  |  |  |  |  |  |  | 0 | IN | APP |  |  |  |  |
| 142242135 |  | Gas Window Design FY12 |  | 290d | 2012-02-01 A | 2013-08-30 A | 142242130 FS-100d | 100% | 2012-02-01 | 2013-04-01 |  |  |  | MECH DES [34.42 h]; SCIENTIST [17.21 h]; VISTNG USERS [17.21 h] | 3,248.6 | 3,264.64 |  | 3205.8788 | ELOUADRHIRI L | 1 | 1 | H | LATIFA E |  |  |  | 12-007 |  |  |  |  |  |  |  |  |  |  |  |  |  |  | 12-053 |  | 1602.9394 | IN | APP |  |  |  |  |
| 142242135a |  | Gas Window Design FY13 |  | 290d | 2012-02-01 A | 2013-08-15 A | 142242135 FS-80d | 100% | 2012-02-01 | 2013-04-01 |  |  |  | MECH DES [5.58 h]; SCIENTIST [2.79 h]; VISTNG USERS [2.79 h] | 526.64 | 529.05 |  | 536.3217 | ELOUADRHIRI L | 1 | 1 | H | LATIFA E |  |  |  | 12-007 |  |  |  |  |  |  |  |  |  |  |  |  |  |  | 12-053 |  | 268.16085 | IN | APP |  |  |  |  |
| 142242000M |  | Space Ready | milestone | 0d | 2012-03-02 A | 2012-03-02 A | 9-120M FS+120d | 100% | 2012-04-02 | 2012-04-02 |  |  |  |  |  |  |  | 0 | ELOUADRHIRI L | 1 | 1 | M | LATIFA E |  |  |  | 12-007 |  |  |  |  |  |  |  |  |  |  |  |  |  |  |  |  |  |  | APP |  |  |  |  |
| 142242060 |  | Alignment Tool and Lasers Quality Control |  | 254d | 2012-03-12 A | 2013-08-30 A | 142242055 FS-300d | 100% | 2012-03-12 | 2013-03-19 |  |  |  | SCIENTIST [40 h]; VISTNG USERS [40 h] | 3,648.23 | 3,668.34 |  | 3712.4 | ELOUADRHIRI L | 1 | 1 | H | LATIFA E |  |  |  | 12-007 |  |  |  |  |  |  |  |  |  |  |  |  |  |  |  | 12-027 | 1856.2 | IN | APP |  |  |  |  |
| 142242010 |  | Prepare electronics for new space |  | 94d | 2012-05-01 A | 2012-09-12 A | 142242005 FS-60d, 142242000M | 100% |  |  |  |  |  | VISTNG USERS [20 h]; SCIENTIST [20 h] | 1,798.8 | 1,798.8 |  | 1798.8 | ELOUADRHIRI L | 1 | 1 | H | LATIFA E |  | 11-026 | 11 -035 | 12-007 |  |  |  |  |  |  |  |  |  |  |  |  |  |  |  |  | 0 | IN | APP | 08-016 | 09-012 | 09-030 |  |
| 142242015 |  | Transport PMTs to new space |  | 14d | 2012-05-01 A | 2012-05-18 A | 142242000M | 100% |  |  |  |  |  | MECH TECH [20 h] | 888.8 | 888.8 |  | 888.8 | ELOUADRHIRI L | 1 | 1 | H | LATIFA E |  |  |  | 12-007 |  |  |  |  |  |  |  |  |  |  |  |  |  |  |  |  | 0 | IN | APP |  |  |  |  |
| 142242045 |  | Procurement Lasers |  | 185d | 2012-05-01 A | 2013-08-30 A | 142242040 FS-70d | 100% | 2012-05-01 | 2013-01-30 |  |  |  | SCIENTIST [20 h]; PROCUREMENT<$50K 60 | 9,686.62 | 1,442.92 |  | 9712.4 | ELOUADRHIRI L | 1 | 1 | D | LATIFA E |  |  |  | 12-007 |  |  |  |  |  |  |  |  |  | 0 | 8255.2 | 825520 | 100 |  |  | 12-027 | 1942.48 | IN | APP |  |  |  | XX |
| 142242040 |  | Procurement Prep of Lasers |  | 4d | 2012-05-09 A | 2012-05-14 A | 142242035 FS-80d | 100% |  |  |  |  |  | SCIENTIST [20 h] | 1,412.2 | 1,412.2 |  | 1412.2 | ELOUADRHIRI L | 1 | 1 | H | LATIFA E |  |  |  | 12-007 |  |  |  |  |  |  |  |  |  |  |  |  |  |  |  |  | 0 | IN | APP |  |  |  |  |
| 142242020 |  | Transport HV Electronics from Hall B to new space |  | 52d | 2012-07-02 A | 2012-09-12 A | 142242015 FS+50d | 100% |  |  |  |  |  | MECH TECH [20 h] | 888.8 | 888.8 |  | 888.8 | ELOUADRHIRI L | 1 | 1 | H | LATIFA E |  |  |  | 12-007 |  |  |  |  |  |  |  |  |  |  |  |  |  |  |  |  | 0 | IN | APP |  |  |  |  |
| 142242025 |  | Installation of Electronics, Black Box for PMTS Quality Control |  | 144d | 2012-07-02 A | 2013-08-30 A | 142242020 FS-10d | 100% | 2012-07-02 | 2013-01-31 |  |  |  | SCIENTIST [20 h]; VISTNG USERS [20 h] | 1,830.69 | 1,843.62 |  | 1798.8 | ELOUADRHIRI L | 1 | 1 | H | LATIFA E |  |  |  | 12-007 |  |  |  |  |  |  |  |  |  |  |  |  |  |  |  |  | 899.4 | IN | APP |  |  |  | XX |
| 142242180 |  | Gas Line Design FY12 |  | 131d | 2012-07-02 A | 2013-08-30 A | 142242070 FS-70d | 100% | 2012-07-02 | 2013-01-11 |  |  |  | SCIENTIST [8.84 h]; VISTNG USERS [8.84 h]; MECH DES [35.35 h] | 2,538.69 | 2,560.18 |  | 2497.8791 | ELOUADRHIRI L | 1 | 1 | H | LATIFA E |  |  |  | 12-007 |  |  |  |  |  |  |  |  |  |  |  |  |  |  | 12-053 |  | 1248.93955 | IN | APP |  |  |  | XX |
| 142242180a |  | Gas Line Design FY13 |  | 131d | 2012-07-02 A | 2013-08-30 A | 142242180 FS-100d | 100% | 2012-07-02 | 2013-01-11 |  |  |  | MECH DES [124.65 h]; SCIENTIST [31.16 h]; VISTNG USERS [31.16 h] | 8,950.84 | 9,026.64 |  | 9088.3111 | ELOUADRHIRI L | 1 | 1 | H | LATIFA E |  |  |  | 12-007 |  |  |  |  |  |  |  |  |  |  |  |  |  |  | 12-053 |  | 4544.15555 | IN | APP |  |  |  | XX |
| 142242185 |  | Procure Gas Line |  | 228d | 2012-07-02 A | 2013-08-30 A | 142242180a FS-120d | 100% | 2012-07-02 | 2013-05-31 |  |  |  | SCIENTIST [40 h]; PROCUREMENT<$50K 60 | 7,016.74 | 2,894.67 |  | 7042 | ELOUADRHIRI L | 1 | 1 | D | LATIFA E |  |  |  | 12-007 |  |  |  |  |  |  |  |  |  | 0 | 4127.6 | 412760 | 100 |  |  |  | 3521 | IN | APP |  |  |  |  |
| 142242210 |  | Transport of FADC, DAQ, Computer, Electronics for 1 Sector |  | 126d | 2012-07-02 A | 2013-08-30 A | 9-130M FS-60d | 100% | 2012-07-02 | 2013-01-04 |  |  |  | MECH TECH [40 h]; SCIENTIST [40 h] | 4,674.24 | 4,716.62 |  | 4748.8 | ELOUADRHIRI L | 1 | 1 | H | LATIFA E |  |  |  | 12-007 |  |  |  |  |  |  |  |  |  |  |  |  |  |  |  |  | 2374.4 | IN | APP |  |  |  | XX |
| 142242065M |  | Space Ready For LTCC Refurb | milestone | 0d | 2012-08-01 A | 2012-08-01 A | 9-120M FS+163d | 100% | 2012-09-04 | 2012-09-04 |  |  |  |  |  |  |  | 0 | ELOUADRHIRI L | 1 | 1 | M | LATIFA E |  |  |  | 12-007 | 12-054F |  |  |  |  |  |  |  |  |  |  |  |  |  |  |  |  |  | APP |  |  |  |  |
| 142242070 |  | Transport 6 CC Sectors to Work Space |  | 30d | 2012-08-06 A | 2012-09-17 A | 142242065M | 100% |  |  |  |  |  |  |  |  |  | 0 | ELOUADRHIRI L | 1 | 1 | Z | LATIFA E |  |  |  | 12-007 | 12-054F |  |  |  |  |  |  |  |  |  |  |  |  |  |  |  |  | IN | APP |  |  |  |  |
| 142242075 |  | Transport Aligment Frame Support to Work Space |  | 134d | 2012-08-13 A | 2013-08-30 A | 142242070 FS-25d | 100% | 2012-08-13 | 2013-03-01 |  |  |  |  |  |  |  | 0 | ELOUADRHIRI L | 1 | 1 | Z | LATIFA E |  |  |  | 12-007 |  |  |  |  |  |  |  |  |  |  |  |  |  |  |  |  |  | IN | APP |  |  |  |  |
| 142242170 |  | Procure PMTs |  | 205d | 2012-08-13 A | 2013-01-02 A | 9-130M FS-20d | 100% | 2012-08-13 | 2013-06-11 |  |  |  | SCIENTIST [40 h]; VISTNG USERS [40 h]; PROCUREMENT<$50K 60; PROCUREMENT>$50K 69 | 133,712.76 | 3,670.88 |  | 133731.8 | ELOUADRHIRI L | 1 | 1 | D | LATIFA E |  |  |  | 12-007 |  |  |  |  |  |  |  |  |  | 0 | 130019.4 | 13001940 | 100 |  |  |  | 0 | IN | APP |  |  |  |  |
| 142242085 |  | Quality Control of Elliptical/Hyperbolic mirrors |  | 179d | 2012-09-10 A | 2013-08-30 A | 142242070 | 100% | 2012-09-10 | 2013-05-31 |  |  |  | SCIENTIST [80 h]; VISTNG USERS [80 h] | 7,405.56 | 7,410.63 |  | 7195.2 | ELOUADRHIRI L | 1 | 1 | U | LATIFA E |  |  |  | 12-007 | 12-054F |  |  |  |  |  |  |  |  |  |  |  |  |  |  |  | 3597.6 | IN | APP |  |  |  |  |
| 142242090 |  | Dimensions check of Elliptical/Hyperbolic mirrors |  | 86d | 2012-09-10 A | 2013-08-30 A | 142242070, 142242085 FS-125d | 100% | 2012-09-10 | 2013-01-17 |  |  |  | SCIENTIST [80 h]; VISTNG USERS [80 h] | 7,384.75 | 7,410.63 |  | 7195.2 | ELOUADRHIRI L | 1 | 1 | U | LATIFA E |  |  |  | 12-007 | 12-054F |  |  |  |  |  |  |  |  |  |  |  |  |  |  |  | 3597.6 | IN | APP |  |  |  | XX |
| 142242105 |  | Al/Mg Deposit Procurement Prep |  | 11d | 2012-10-01 A | 2012-10-15 A | 142242100 FS+7d | 100% |  |  |  |  |  | SCIENTIST [80 h] | 5,828.8 | 5,828.8 |  | 5828.8 | ELOUADRHIRI L | 1 | 1 | H | LATIFA E |  |  |  | 12-007 | 12-054 |  |  |  |  |  |  |  |  |  |  |  |  |  |  |  | 0 | IN | APP |  |  |  |  |
| 142242095 |  | Create Manufacturing Drawings |  | 94d | 2012-11-12 A | 2013-08-30 A | 9-130M, 142242090 FS-125d | 100% | 2012-11-12 | 2013-04-04 |  |  |  | MECH DES [160 h] | 7,953.6 | 7,953.6 |  | 7953.6 | ELOUADRHIRI L | 1 | 1 | H | LATIFA E |  |  |  | 12-007 | 12-054 |  |  |  |  |  |  |  |  |  |  |  |  |  | 12-053 |  | 3976.8 | IN | APP |  |  |  |  |
| 142242145 |  | Complete Design Box Walls FY12 |  | 79d | 2012-12-03 A | 2013-08-30 A | 142242140 FS-75d | 100% | 2013-05-13 | 2013-09-03 |  |  |  | SCIENTIST [25.09 h]; VISTNG USERS [25.09 h]; MECH DES [98.52 h] | 7,226.04 | 7,226.04 |  | 7002.303 | ELOUADRHIRI L | 1 | 1 | H | LATIFA E |  |  |  | 12-007 |  |  |  |  |  |  |  |  |  |  |  |  |  |  | 12-053 |  | 3501.1515 | IN | APP |  |  |  |  |
| 142242145a |  | Complete Design Box Walls FY13 |  | 6d | 2012-12-03 A | 2013-08-30 A | 142242145 FS-80d | 100% | 2013-09-04 | 2013-09-11 |  |  |  | SCIENTIST [1.91 h]; VISTNG USERS [1.91 h]; MECH DES [7.48 h] | 549.09 | 549.09 |  | 549.0979 | ELOUADRHIRI L | 1 | 1 | H | LATIFA E |  |  |  | 12-007 |  |  |  |  |  |  |  |  |  |  |  |  |  |  | 12-053 |  | 274.54895 | IN | APP |  |  |  |  |
| 142242215 |  | Installation of FADC, DAQ, Computer, Electronics for 1 Sector |  | 36d | 2013-02-01 A | 2013-08-30 A | 142242210 FS-50d | 100% | 2013-03-01 | 2013-04-19 |  |  |  |  |  |  |  | 0 | ELOUADRHIRI L | 1 | 1 | H | LATIFA E |  |  |  | 12-007 |  |  |  |  |  |  |  |  |  |  |  |  |  |  |  |  |  | IN | APP |  |  |  | XX |
| 142242100 |  | Removal of mirrors |  | 56d | 2013-03-04 A | 2013-07-15 A | 9-130M FS+60d, 142242090 FS-122d | 100% | 2013-04-01 | 2013-06-18 |  |  |  | MECH TECH [40 h]; SCIENTIST [20 h]; VISTNG USERS [20 h] | 3,690.6 | 3,690.6 |  | 3690.6 | ELOUADRHIRI L | 1 | 1 | U | LATIFA E |  |  |  | 12-007 | 12-054 |  |  |  |  |  |  |  |  |  |  |  |  |  | 12-053 |  | 369.06 | IN | APP |  |  |  |  |
| 142242150 |  | PMTs Removal |  | 77d | 2013-03-04 A | 2013-07-15 A | 142242145a FS-15d | 100% | 2013-05-06 | 2013-08-22 |  |  |  | MECH TECH [80 h] | 3,668.8 | 3,668.8 |  | 3668.8 | ELOUADRHIRI L | 1 | 1 | U | LATIFA E |  |  |  | 12-007 | 12-054 |  |  |  |  |  |  |  |  |  |  |  |  |  |  |  | 366.88 | IN | APP |  |  |  |  |
| 142242175 |  | PMTs Quality Control |  | 99d | 2013-03-04 A | 2013-08-30 A | 142242170 FS-75d | 100% | 2013-04-01 | 2013-08-19 |  |  |  | SCIENTIST [40 h]; VISTNG USERS [40 h] | 3,712.4 | 3,712.4 |  | 3712.4 | ELOUADRHIRI L | 1 | 1 | H | LATIFA E |  |  |  | 12-007 |  |  |  |  |  |  |  |  |  |  |  |  |  |  |  |  | 1856.2 | IN | APP |  |  |  |  |
| 142242080 |  | Installation and Aligment of Lasers, Tools and Frame Support |  | 59d | 2013-05-06 A | 2013-08-30 A | 142242075 FS-20d | 100% | 2013-07-03 | 2013-09-25 |  |  |  | MECH TECH [40 h]; SCIENTIST [20 h]; VISTNG USERS [20 h] | 3,690.6 | 3,690.6 |  | 3576.4 | ELOUADRHIRI L | 1 | 1 | H | LATIFA E |  |  |  | 12-007 |  |  |  |  |  |  |  |  |  |  |  |  |  |  |  |  | 1788.2 | IN | APP |  |  |  |  |
| 142242050 |  | Alignment Tool Manufacturing |  | 53d | 2013-08-30 A | 2013-08-30 A | 142242040 FS+12d, 142242035 FS-27d | 100% | 2013-09-03 | 2013-11-14 |  |  |  | MSHOP; MECH DES [20 h]; VISTNG USERS [20 h] | 5,920.97 | 1,393.2 |  | 5850 | ELOUADRHIRI L | 1 | 1 | H | LATIFA E |  |  |  | 12-007 |  |  |  |  |  |  |  |  |  |  |  |  |  |  |  |  | 5850 | IN | APP |  |  |  |  |
| 142242055 |  | Alignment Tool and Lasers Installation |  | 16d | 2013-08-30 A | 2013-08-30 A | 142242045 FS-10d, 142242050 FS-10d | 100% | 2013-11-01 | 2013-11-22 |  |  |  | SCIENTIST [20 h]; MECH TECH [20 h] | 2,450 | 2,374.4 |  | 2374.4 | ELOUADRHIRI L | 1 | 1 | H | LATIFA E |  |  |  | 12-007 |  |  |  |  |  |  |  |  |  |  |  |  |  |  |  | 12-027 | 2374.4 | IN | APP |  |  |  |  |
| 142242110 |  | Al/Mg Deposit Procurement |  | 101d | 2013-08-30 A | 2013-08-30 A | 142242105 FS+10d | 100% | 2013-09-03 | 2014-02-03 |  |  |  | MECH TECH [10.3 h]; PROCUREMENT<$50K 60 NO ESCALATION FY14; PROCUREMENT>$50K 69 NO ESCALATION FY14 | 484.42 | 472.36 |  | 472.358 | ELOUADRHIRI L | 1 | 1 | D | LATIFA E |  |  |  | 12-007 | 12-054 |  |  |  |  |  |  |  |  |  |  |  |  |  |  |  | 53429.4 | IN | APP |  |  |  |  |
| 142242155 |  | Walls Manufacturing and Installation |  | 79d | 2013-08-30 A | 2013-08-30 A | 142242150 FS-49d, 142242145a | 100% | 2013-09-18 | 2014-01-16 |  |  |  | MECH TECH [40 h]; MSHOP | 15,300.85 | 1,834.4 |  | 15249.1 | ELOUADRHIRI L | 1 | 1 | H | LATIFA E |  |  |  | 12-007 | 12-054 |  |  |  |  |  |  |  |  |  |  |  |  |  |  |  | 15249.1 | IN | APP |  |  |  |  |
| 142242165 |  | Procure Cables FY12 |  | 93d | 2013-08-30 A | 2013-08-30 A | 9-130M FS+165d, 9-120M FS+205d | 100% | 2013-09-03 | 2014-01-22 |  |  |  | SCIENTIST [23.07 h]; VISTNG USERS [23.07 h] | 2,194.73 | 2,141.13 |  | 2074.9158 | ELOUADRHIRI L | 1 | 1 | D | LATIFA E |  |  |  | 12-007 |  |  |  |  |  |  |  |  |  |  |  |  |  |  | 12-053 |  | 2074.9158 | IN | APP |  |  |  |  |
| 142242165a |  | Procure Cables FY13 |  | 35d | 2013-08-30 A | 2013-08-30 A | 142242165 FS-95d, 9-130M FS+165d | 100% | 2013-09-03 | 2013-10-21 |  |  |  | SCIENTIST [16.93 h]; VISTNG USERS [16.93 h] | 1,592.75 | 1,571.27 |  | 1571.2733 | ELOUADRHIRI L | 1 | 1 | D | LATIFA E |  |  |  | 12-007 |  |  |  |  |  |  |  |  |  |  |  |  |  |  | 12-053 |  | 1571.2733 | IN | APP |  |  |  |  |
| 142242165b |  | Procure Cables Procurement |  | 137d | 2013-08-30 A | 2013-08-30 A | 9-130M FS+165d, 9-120M FS+205d | 100% | 2013-09-03 | 2014-03-26 |  |  |  | PROCUREMENT<$50K 60 NO ESCALATION FY13 | 15,000 |  |  | 15000 | ELOUADRHIRI L | 1 | 1 | D | LATIFA E |  |  |  | 12-007 |  |  |  |  |  |  |  |  |  | 0 | 15000 | 1500000 | 100 |  | 12-053 |  | 15000 | IN | APP |  |  |  |  |
| 142242190 |  | Install Gas Line |  | 15d | 2013-08-30 A | 2013-08-30 A | 142242185 FS-9d | 100% | 2013-09-09 | 2013-09-27 |  |  |  | MECH TECH [80 h] | 3,668.8 | 3,668.8 |  | 3668.8 | ELOUADRHIRI L | 1 | 1 | H | LATIFA E |  |  |  | 12-007 |  |  |  |  |  |  |  |  |  |  |  |  |  |  |  |  | 3668.8 | IN | APP |  |  |  |  |
| 142242195 |  | Gas Line Quality Control |  | 15d | 2013-08-30 A | 2013-08-30 A | 142242190 FS+9d | 100% | 2013-10-11 | 2013-10-31 |  |  |  | MECH TECH [40 h] | 1,892.8 | 1,834.4 |  | 1834.4 | ELOUADRHIRI L | 1 | 1 | H | LATIFA E |  |  |  | 12-007 |  |  |  |  |  |  |  |  |  |  |  |  |  |  |  |  | 1834.4 | IN | APP |  |  |  |  |
| 142242200 |  | Elliptical Mirror Tool/Frame Alignment |  | 22d | 2013-08-30 A | 2013-08-30 A | 142242055 FS+61d, 142242080, 142242095 | 100% | 2014-03-04 | 2014-04-02 |  |  |  | MECH TECH [40 h]; MECH DES [40 h] | 3,944.8 | 3,822.8 |  | 3822.8 | ELOUADRHIRI L | 1 | 1 | H | LATIFA E |  |  |  | 12-007 |  |  |  |  |  |  |  |  |  |  |  |  |  |  |  | 12-027 | 3822.8 | IN | APP |  |  |  |  |
| 142242205 |  | Mirrors Laser Alignments |  | 102d | 2013-08-30 A | 2013-08-30 A | 142242200 | 100% | 2014-04-03 | 2014-08-26 |  |  |  | MECH TECH [70.57 h]; SCIENTIST [105.86 h]; VISTNG USERS [105.86 h] | 13,477.58 | 13,061.2 |  | 13061.205438 | ELOUADRHIRI L | 1 | 1 | H | LATIFA E |  |  |  | 12-007 |  |  |  |  |  |  |  |  |  |  |  |  |  |  |  | 12-027 | 24059.75 | IN | APP |  |  |  |  |

Notes:
- 242241405b: Steps: Installation of 12 Half-sectors without gluing them together; Gluing 6 Half-sectors together; Gluing of remaining 6 Half-sectors together; Gluing of the First and Second halfs together; Installation of the ring with bridge pieces glued to the ring; Gluing of the ring with bridge pieces to the mirror
- 242241410: Steps: Installation of the testing equipment; Quality control and tests of all Half-sectors
- 242241605: Steps: Dry fit and alignment of the carbon cone with spokes in CV; Final assembly of the cone in the Containment Vessel
- 242241610: Steps: Preparation of the exit window for installation; Dry fit of the exit window to the CV with carbon cone installed; Gluing of the window to the CV
- 242241647d5: Steps: Light leak tests and fixing possible leaks; Gas leak tests of CV and fixing possible leaks
- 242241640: Steps: Installation of the mounting fixtures in the CV; Preparation of the Mirror for lifting off the table; Installation of the mMirror in the CV; Alignment of the Mirror and geometry tests

| ID | Activity | Duration | Start | Finish | Predecessors | Complete | Remaining | Planned start | Planned finish | Total float | Free float | Calendar | Resources | Cost | Actual cost | Calculated Remaining Total Cost | MONTHLY EV COST | PHAS - Project Phase | RESP - Responsibility | STRT%COMP for CM EVM | FNSH%COMP for CM EVM | Advance Purchase Plan > 500K | EVMS Reporting Codes | CAM RESPONSIBLE | CR 12-007 | CR 12-053 | Claimed Material Divider | ReBaseline Actuals Adjustment | Original Activity ID Rebaseline | PRIOR MONTH EV COST | CR 13-002 | BOE Labor | BOE Expenses | CR 13-015 | Post Rebaseline | CR 14-001 | CR 12-027 | CR 12-054 | Remaining Material Cost Based on % Compl | Claimed Material Cost Based on % Complet | Initial Claimed Material Calc | BOE Procurement | Obligated Prior to Rebaseline | Activities with Steps |
| --- | --- | --- | --- | --- | --- | --- | --- | --- | --- | --- | --- | --- | --- | --- | --- | --- | --- | --- | --- | --- | --- | --- | --- | --- | --- | --- | --- | --- | --- | --- | --- | --- | --- | --- | --- | --- | --- | --- | --- | --- | --- | --- | --- | --- |
| 142242220 | Online Calibration Design FY12 | 58d | 2013-08-30 A | 2013-08-30 A | 9-120M FS+168d | 100% |  | 2013-09-03 | 2013-11-21 |  |  |  | SCIENTIST [103.01 h]; VISTNG USERS [82.49 h] | 9,342.14 | 9,150.99 | 8868.0678 | 8868.0678 | IN | ELOUADRHIRI L | 1 | 1 | APP | H | LATIFA E | 12-007 | 12-053 |  |  |  |  |  |  |  |  |  |  |  |  |  |  |  |  |  |  |
| 142242220a | Online Calibration Design FY13 | 105d | 2013-08-30 A | 2013-08-30 A | 142242220 | 100% |  | 2013-11-22 | 2014-05-01 |  |  |  | SCIENTIST [162.99 h]; VISTNG USERS [130.51 h] | 14,940.79 | 14,479.12 | 14479.1259 | 14479.1259 | IN | ELOUADRHIRI L | 1 | 1 | APP | H | LATIFA E | 12-007 | 12-053 |  |  |  |  |  |  |  |  |  |  |  |  |  |  |  |  |  |  |
| 142242225 | Online Calibration Test | 84d | 2013-08-30 A | 2013-08-30 A | 142242220a FS+30d | 100% |  | 2014-06-16 | 2014-10-13 |  |  |  | SCIENTIST [69.53 h]; VISTNG USERS [69.53 h] | 6,658.41 | 6,452.61 | 7424.8 | 6452.61525 | IN | ELOUADRHIRI L | 1 | 1 | APP | H | LATIFA E | 12-007 |  |  |  |  |  |  |  |  |  |  |  |  |  |  |  |  |  |  |  |
| 142242245 | Re-Baseline Actuals Adjustment | 1d | 2013-08-30 A | 2013-08-30 A |  | 100% |  | 2013-09-03 | 2013-09-03 |  |  |  | PROCUREMENT>$50K 69 NO ESCALATION | -25,767.92 |  |  |  |  |  |  |  |  |  |  |  |  | 100 | ADJ |  |  |  |  |  |  |  |  |  |  |  |  |  |  |  |  |
| 242242036 | Wavelength Shifting tests Labor/Expenses FY13 | 20d | 2013-09-03 A | 2013-11-15 | 9-130M FS+228d | 50% | 11d | 2013-10-01 | 2013-10-28 | 229d | 0d | 8/5 M-F w/JLAB Holidays ReBaseline | SUPPLIES & MATERIALS; SCIENTIST [18.06 h] | 2,648.07 | 848.94 |  | 0 | IN | ELOUADRHIRI L | 1 | 1 | APP | H | LATIFA E | 12-007 |  |  |  | 242242036 | 1303.0858 | 13-002F | PE | PE | 13-015 | PR |  |  |  |  |  |  |  |  |  |
| 242242036a | Wavelength Shifting tests Labor/Expenses FY14 | 11d | 2013-09-03 A | 2013-11-15 | 242242036 FS-20d | 50% | 11d | 2013-10-01 | 2013-10-15 | 229d | 0d | 8/5 M-F w/JLAB Holidays ReBaseline | SUPPLIES & MATERIALS; SCIENTIST [9.94 h] | 1,479.61 | 467.24 |  | 0 | IN | ELOUADRHIRI L | 1 | 1 | APP | H | LATIFA E | 12-007 |  |  |  | 242242036 | 739.8046 | 13-002F | PE | PE | 13-015 | PR | 14-001 |  |  |  |  |  |  |  |  |
| 242242310 | PMTS, Mirrors Holes Drill | 213d | 2013-09-03 A | 2014-08-19 | 242242305 FS-260d | 50% | 195d | 2013-12-18 | 2014-10-28 | 232d | 1d | 8/5 M-F w/JLAB Holidays ReBaseline | MECH TECH [16 h] | 757.12 | 134.83 |  | 0 | IN | ELOUADRHIRI L | 1 | 1 | APP | H | LATIFA E | 12-007 |  |  |  | 242242310 | 378.56 | 13-002F | PE |  | 13-015 | PR | 14-001 | 12-027 | 12-054 |  |  |  |  |  |  |
| 242242031 | Quality Control of Existing PMTs FY13 | 15d | 2013-10-01 A | 2014-06-10 | 9-130M FS+233d | 5% | 146d | 2013-11-01 | 2013-11-21 | 231d | 0d | 8/5 M-F w/JLAB Holidays ReBaseline | CONTRB UNIV LBR [19.57 h]; VISTNG USERS [13.04 h]; SCIENTIST [0.98 h] | 342.14 | 46.56 |  | 16.5761774 | IN | ELOUADRHIRI L | 1 | 1 | APP | U | LATIFA E | 12-007 |  |  |  | 242242031 |  | 13-002F | PE |  | 13-015 | PR |  |  |  |  |  |  |  |  |  |
| 242242031a | Quality Control of Existing PMTs FY14 | 169d | 2013-10-01 A | 2014-06-10 | 242242031 FS-146d | 5% | 146d | 2013-11-22 | 2014-08-04 | 231d | 0d | 8/5 M-F w/JLAB Holidays ReBaseline | CONTRB UNIV LBR [220.43 h]; VISTNG USERS [146.96 h]; SCIENTIST [11.02 h] | 3,854.42 | 524.57 |  | 192.7209049 | IN | ELOUADRHIRI L | 1 | 1 | APP | U | LATIFA E | 12-007 |  |  |  | 242242031 |  | 13-002F | PE |  | 13-015 | PR | 14-001 |  |  |  |  |  |  |  |  |
| 242242045 | Procurement Lasers - Procurement | 95d | 2013-10-01 A | 2013-10-21 A | 9-130M FS+228d, 9-140M FS+33d | 100% |  | 2013-11-15 | 2014-04-11 |  |  | 8/5 M-F w/JLAB Holidays ReBaseline | SCIENTIST; PROCUREMENT<$50K 60 NO ESCALATION FY14 | 1,651.04 |  |  | 1651.04 | IN | ELOUADRHIRI L | 1 | 1 | APP | D | LATIFA E | 12-007 |  | 100 |  | 242242045 |  | 13-002F | PE |  | 13-015 | PR |  | 12-027 |  | 0 | 1651.04 | 165104 | PE | OB-2 |  |
| 242242045a | Procurement Lasers - Labor FY13 | 20d | 2013-10-01 A | 2013-10-21 A | 9-140M FS+33d | 100% |  | 2013-11-15 | 2013-12-16 |  |  | 8/5 M-F w/JLAB Holidays ReBaseline | SCIENTIST [0.51 h] | 38.34 | 38.34 |  | 37.1586 | IN | ELOUADRHIRI L | 1 | 1 | APP | D | LATIFA E | 12-007 |  |  |  | 242242045 |  | 13-002F | PE |  | 13-015 | PR |  | 12-027 |  |  |  |  | PE |  |  |
| 242242045b | Procurement Lasers - Labor FY14 | 75d | 2013-10-01 A | 2013-10-21 A | 242242045a | 100% |  | 2013-12-17 | 2014-04-11 |  |  | 8/5 M-F w/JLAB Holidays ReBaseline | SCIENTIST [1.89 h] | 142.09 | 142.09 |  | 142.0902 | IN | ELOUADRHIRI L | 1 | 1 | APP | D | LATIFA E | 12-007 |  |  |  | 242242045 |  | 13-002F | PE |  | 13-015 | PR | 14-001 | 12-027 |  |  |  |  | PE |  |  |
| 242242095 | Create Manufacturing Drawings FY13 | 20d | 2013-10-01 A | 2013-12-12 | 9-130M FS+228d, 9-140M FS+23d | 50% | 28d | 2013-11-01 | 2013-12-02 | 243d | 0d | 8/5 M-F w/JLAB Holidays ReBaseline | SCIENTIST [1.71 h] | 128.56 | 57.98 |  | 62.2953 | IN | ELOUADRHIRI L | 1 | 1 | APP | H | LATIFA E | 12-007 | 12-053 |  |  | 242242095 |  | 13-002F | PE |  | 13-015 | PR |  |  | 12-054 |  |  |  |  |  |  |
| 242242095a | Create Manufacturing Drawings FY14 | 8d | 2013-10-01 A | 2013-12-12 | 242242095 FS-30d | 50% | 28d | 2013-12-03 | 2013-12-12 | 243d | 0d | 8/5 M-F w/JLAB Holidays ReBaseline | SCIENTIST [0.69 h] | 51.87 | 23.39 |  | 25.9371 | IN | ELOUADRHIRI L | 1 | 1 | APP | H | LATIFA E | 12-007 | 12-053 |  |  | 242242095 |  | 13-002F | PE |  | 13-015 | PR | 14-001 |  | 12-054 |  |  |  |  |  |  |
| 242242105 | Al/Mg Deposit Procurement Prep FY13 | 20d | 2013-10-01 A | 2014-01-03 | 9-130M FS+228d, 9-140M | 50% | 36d | 2013-11-15 | 2013-12-16 | 167d | 0d | 8/5 M-F w/JLAB Holidays ReBaseline | SCIENTIST [6.15 h] | 462.36 | 180.24 |  | 224.0445 | IN | ELOUADRHIRI L | 1 | 1 | APP | H | LATIFA E | 12-007 |  |  |  | 242242105 |  | 13-002F | PE |  | 13-015 | PR |  |  | 12-054 |  |  |  |  |  |  |
| 242242105a | Al/Mg Deposit Procurement Prep FY14 | 6d | 2013-10-01 A | 2014-01-03 | 242242105 FS-36d | 50% | 36d | 2013-12-17 | 2014-01-03 | 190d | 23d | 8/5 M-F w/JLAB Holidays ReBaseline | SCIENTIST [1.85 h] | 139.08 | 54.22 |  | 69.5415 | IN | ELOUADRHIRI L | 1 | 1 | APP | H | LATIFA E | 12-007 |  |  |  | 242242105 |  | 13-002F | PE |  | 13-015 | PR | 14-001 |  | 12-054 |  |  |  |  |  |  |
| 242242145a | Complete Design Box Walls FY13 | 20d | 2013-10-01 A | 2014-01-03 | 9-130M FS+228d, 9-140M FS+23d | 50% | 36d | 2013-11-01 | 2013-12-02 | 424d | 0d | 8/5 M-F w/JLAB Holidays ReBaseline | SCIENTIST [2.22 h] | 166.9 | 65.06 |  | 80.8746 | IN | ELOUADRHIRI L | 1 | 1 | APP | H | LATIFA E | 12-007 | 12-053 |  |  | 242242145a |  | 13-002F | PE |  | 13-015 | PR |  |  |  |  |  |  |  |  |  |
| 242242145aa | Complete Design Box Walls FY14 | 16d | 2013-10-01 A | 2014-01-03 | 242242145a FS-36d | 50% | 36d | 2013-12-03 | 2014-01-03 | 424d | 0d | 8/5 M-F w/JLAB Holidays ReBaseline | SCIENTIST [1.78 h] | 133.82 | 52.17 |  | 66.9102 | IN | ELOUADRHIRI L | 1 | 1 | APP | H | LATIFA E | 12-007 | 12-053 |  |  | 242242145a |  | 13-002F | PE |  | 13-015 | PR | 14-001 |  |  |  |  |  |  |  |  |
| 242242220a | Online Calibration Design FY13 | 20d | 2013-10-01 A | 2014-06-27 | 9-140M FS+23d, 9-130M FS+228d |  | 159d | 2013-11-01 | 2013-12-02 | 239d | 0d | 8/5 M-F w/JLAB Holidays ReBaseline | SCIENTIST [3.96 h] | 297.71 | 37.62 |  | 0 | IN | ELOUADRHIRI L | 1 | 1 | APP | S | LATIFA E | 12-007 | 12-053 |  |  | 242242220a |  | 13-002F | PE |  | 13-015 | PR |  |  |  |  |  |  |  |  | ST |
| 242242220aa | Online Calibration Design FY14 | 182d | 2013-10-01 A | 2014-06-27 | 242242220a FS-159d |  | 159d | 2013-12-03 | 2014-08-28 | 239d | 0d | 8/5 M-F w/JLAB Holidays ReBaseline | SCIENTIST [36.04 h] | 2,709.49 | 342.41 |  | 0 | IN | ELOUADRHIRI L | 1 | 1 | APP | S | LATIFA E | 12-007 | 12-053 |  |  | 242242220a |  | 13-002F | PE |  | 13-015 | PR | 14-001 |  |  |  |  |  |  |  | ST |
| 242242222 | Online HV Matching Design FY13 | 20d | 2013-10-01 A | 2014-06-27 | 242242220aa FS-202d, 242242220a FS-202d |  | 159d | 2013-11-01 | 2013-12-02 | 239d | 0d | 8/5 M-F w/JLAB Holidays ReBaseline | SCIENTIST [4.36 h] | 327.78 | 41.42 |  | 0 | IN | ELOUADRHIRI L | 1 | 1 | APP | S | LATIFA E | 12-007 | 12-053 |  |  | 242242222 |  | 13-002F | PE |  | 13-015 | PR |  |  |  |  |  |  |  |  | ST |
| 242242222a | Online HV Matching Design FY14 | 182d | 2013-10-01 A | 2014-06-27 | 242242220aa FS-202d, 242242222 FS-159d |  | 159d | 2013-12-03 | 2014-08-28 | 239d | 0d | 8/5 M-F w/JLAB Holidays ReBaseline | SCIENTIST [39.64 h] | 2,980.14 | 376.61 |  | 0 | IN | ELOUADRHIRI L | 1 | 1 | APP | S | LATIFA E | 12-007 | 12-053 |  |  | 242242222 |  | 13-002F | PE |  | 13-015 | PR | 14-001 |  |  |  |  |  |  |  | ST |
| 242242245 | Simulation of Sagging Test | 100d | 2013-10-01 A | 2014-03-04 | 9-140M | 50% | 77d | 2013-11-01 | 2014-04-04 | 383d | 0d | 8/5 M-F w/JLAB Holidays ReBaseline | SCIENTIST [24 h] | 1,804.32 | 414.99 |  | 902.16 | IN | ELOUADRHIRI L | 1 | 1 | APP | H | LATIFA E | 12-007 |  |  |  | 242242245 |  | 13-002F | PE |  | 13-015 | PR | 14-001 | 12-027 | 12-054 |  |  |  |  |  |  |
| 242242290 | Cut Line Mark | 37d | 2013-10-01 A | 2014-01-06 | 9-130M FS+228d, 9-140M | 50% | 37d | 2013-12-02 | 2014-02-03 | 349d | 0d | 8/5 M-F w/JLAB Holidays ReBaseline | MECH TECH [12.8 h] | 605.7 | 232.18 |  | 293.504 | IN | ELOUADRHIRI L | 1 | 1 | APP | H | LATIFA E | 12-007 |  |  |  | 242242290 |  | 13-002F | PE |  | 13-015 | PR |  | 12-027 | 12-054 |  |  |  |  |  |  |
| 242242161 | HV Cables Catalog and Tagging | 103d | 2013-10-12 A | 2014-04-18 | 9-140M | 50% | 110d | 2013-11-12 | 2014-04-18 | 311.5d | 0d | 8/5 M-F w/JLAB Holidays ReBaseline | MECH TECH [16 h] | 757.12 | 85.48 |  | 378.56 | IN | ELOUADRHIRI L | 1 | 1 | APP | H | LATIFA E | 12-007 |  |  |  | 242242161 |  | 13-002F | PE |  | 13-015 | PR | 14-001 |  | 12-054 |  |  |  |  |  |  |
| 242242030 | Quality Control of PMTs | 162d | 2013-11-01 | 2014-07-02 | 9-140M FS+7d |  |  |  |  | 331d | 199d | 8/5 M-F w/JLAB Holidays ReBaseline | CONTRB UNIV LBR [120 h] |  |  |  | 0 | IN | ELOUADRHIRI L | 1 | 1 | APP | Z | LATIFA E | 12-007 |  |  |  | 242242030 |  | 13-002F | PE |  | 13-015 | PR |  |  |  |  |  |  |  |  |  |
| 242242085 | Quality Control of Elliptical/Hyperbolic mirrors | 178d | 2013-11-01 | 2014-07-25 | 9-140M FS+22d |  |  |  |  | 347d | 77d | 8/5 M-F w/JLAB Holidays ReBaseline | SCIENTIST [48 h]; VISTNG USERS [320 h] | 10,197.44 |  |  | 0 | IN | ELOUADRHIRI L | 1 | 1 | APP | S | LATIFA E | 12-007 |  |  |  | 242242085 |  | 13-002F | PE |  | 13-015 | PR | 14-001 |  | 12-054F |  |  |  |  |  | ST |
| 242242325 | Spine Refusrbish FY13 | 20d | 2013-11-01 | 2013-12-02 | 242242320 FS-265d, 242242315 FS-265d |  |  |  |  | 212d | 0d | 8/5 M-F w/JLAB Holidays ReBaseline | MECH TECH [1.42 h] | 67.19 |  |  | 0 | IN | ELOUADRHIRI L | 1 | 1 | APP | H | LATIFA E | 12-007 |  |  |  | 242242325 |  | 13-002F | PE |  | 13-015 | PR |  | 12-027 | 12-054 |  |  |  |  |  |  |
| 242242335 | Box Refurbish Consumables | 281d | 2013-11-01 | 2014-12-22 | 9-140M FS+23d |  |  |  |  | 212d | 80d | 8/5 M-F w/JLAB Holidays ReBaseline | SUPPLIES & MATERIALS | 18,574.2 |  |  | 0 | IN | ELOUADRHIRI L | 1 | 1 | APP | D | LATIFA E | 12-007 |  |  |  | 242242335 |  | 13-002F |  | PE | 13-015 | PR | 14-001 |  | 12-054F |  |  |  |  |  |  |
| 242242340 | Sector 2 Box Refurbish | 28d | 2013-11-01 | 2013-12-12 | 9-140M FS+21d |  |  |  |  | 183d | 0d | 8/5 M-F w/JLAB Holidays ReBaseline | MECH TECH [320 h] | 15,142.4 |  |  | 0 | IN | ELOUADRHIRI L | 1 | 1 | APP | S | LATIFA E | 12-007 |  |  |  | 242242340 |  | 13-002F | PE |  | 13-015 | PR | 14-001 |  | 12-054F |  |  |  |  |  | ST |
| 242242162 | Divider Modifications Design and Test | 55d | 2013-11-12 | 2014-02-11 | 9-140M FS+30d |  |  |  |  | 226d | 0d | 8/5 M-F w/JLAB Holidays ReBaseline | SUPPLIES & MATERIALS; SCIENTIST [8 h] | 1,633.34 |  |  | 0 | IN | ELOUADRHIRI L | 1 | 1 | APP | H | LATIFA E | 12-007 |  |  |  | 242242162 |  | 13-002F | PE | PE | 13-015 | PR | 14-001 |  | 12-054 |  |  |  |  |  |  |
| 242242165b | Procure Cables Procurement | 149d | 2013-11-12 | 2014-06-24 | 9-140M FS+30d |  |  |  |  | 337d | 205d | 8/5 M-F w/JLAB Holidays ReBaseline | SCIENTIST [32 h]; PROCUREMENT<$50K 60 | 24,240.76 |  |  | 0 | IN | ELOUADRHIRI L | 1 | 1 | APP | D | LATIFA E | 12-007 | 12-053 | 100 |  | 242242165b |  | 13-002F | PE |  | 13-015 | PR | 14-001 |  |  | 21835 | 0 | 0 | PE |  |  |
| 242242295 | Wall Cut-Off FY13 | 1d | 2013-11-14 | 2013-11-14 | 242242290 FS-28d |  |  |  |  | 349d | 0d | 8/5 M-F w/JLAB Holidays ReBaseline | MECH TECH [0.12 h] | 5.68 |  |  | 0 | IN | ELOUADRHIRI L | 1 | 1 | APP | H | LATIFA E | 12-007 |  |  |  | 242242295 |  | 13-002F | PE |  | 13-015 | PR |  | 12-027 | 12-054 |  |  |  |  |  |  |
| 242242050 | Alignment Tool Manufacturing Labor/Expenses FY13 | 7d | 2013-11-15 | 2013-11-25 | 9-140M FS+33d, 9-130M FS+241d |  |  |  |  | 177d | 0d | 8/5 M-F w/JLAB Holidays ReBaseline | MECH TECH [4.75 h]; MSHOP | 758.67 |  |  | 0 | IN | ELOUADRHIRI L | 1 | 1 | APP | D | LATIFA E | 12-007 |  |  |  | 242242050 |  | 13-002F | PE | PE | 13-015 | PR |  |  |  |  |  |  |  |  |  |
| 242242107 | Al/Mg Laxon/Acrylic Re-Coating Test Procurement Labor FY13 | 15d | 2013-11-15 | 2013-12-09 | 9-140M FS+33d, 9-130M FS+233d |  |  |  |  | 193d | 0d | 8/5 M-F w/JLAB Holidays ReBaseline | SCIENTIST [8 h] | 601.44 |  |  | 0 | IN | ELOUADRHIRI L | 1 | 1 | APP | H | LATIFA E | 12-007 |  |  |  | 242242107 |  | 13-002F | PE |  | 13-015 | PR |  |  | 12-054 |  |  |  |  |  |  |
| 242242152 | Window Procurement | 139d | 2013-11-15 | 2014-06-13 | 9-130M FS+228d, 9-140M FS+33d |  |  |  |  | 132d | 0d | 8/5 M-F w/JLAB Holidays ReBaseline | SCIENTIST; PROCUREMENT<$50K 60 NO ESCALATION FY14 | 2,800 |  |  | 0 | IN | ELOUADRHIRI L | 1 | 1 | APP | D | LATIFA E | 12-007 |  | 100 |  | 242242152 |  | 13-002F | PE |  | 13-015 | PR |  |  | 12-054 | 2800 | 0 | 0 | PE |  |  |
| 242242152a | Window Procurement - Labor FY13 | 20d | 2013-11-15 | 2013-12-16 | 9-140M FS+33d |  |  |  |  | 132d | 0d | 8/5 M-F w/JLAB Holidays ReBaseline | SCIENTIST [4.6 h] | 345.83 |  |  | 0 | IN | ELOUADRHIRI L | 1 | 1 | APP | D | LATIFA E | 12-007 |  |  |  | 242242152 |  | 13-002F | PE |  | 13-015 | PR |  |  | 12-054 |  |  |  | PE |  |  |
| 242242295a | Wall Cut-Off FY14 | 134d | 2013-11-15 | 2014-06-06 | 242242295 |  |  |  |  | 349d | 217d | 8/5 M-F w/JLAB Holidays ReBaseline | MECH TECH [15.88 h] | 751.44 |  |  | 0 | IN | ELOUADRHIRI L | 1 | 1 | APP | H | LATIFA E | 12-007 |  |  |  | 242242295 |  | 13-002F | PE |  | 13-015 | PR | 14-001 | 12-027 | 12-054 |  |  |  |  |  |  |
| 242242050a | Alignment Tool Manufacturing Labor/Expenses FY14 | 52d | 2013-11-26 | 2014-02-20 | 242242050 |  |  |  |  | 177d | 0d | 8/5 M-F w/JLAB Holidays ReBaseline | MECH TECH [35.25 h]; MSHOP | 5,760.65 |  |  | 0 | IN | ELOUADRHIRI L | 1 | 1 | APP | D | LATIFA E | 12-007 |  |  |  | 242242050 |  | 13-002F | PE | PE | 13-015 | PR | 14-001 |  |  |  |  |  |  |  |  |
| 242242280 | Frame Support FY13 | 9d | 2013-12-02 | 2013-12-12 | 9-140M FS+42d, 9-130M FS+239d |  |  |  |  | 419d | 0d | 8/5 M-F w/JLAB Holidays ReBaseline | MECH TECH [2.62 h] | 123.98 |  |  | 0 | IN | ELOUADRHIRI L | 1 | 1 | APP | H | LATIFA E | 12-007 |  |  |  | 242242280 |  | 13-002F | PE |  | 13-015 | PR |  | 12-027 | 12-054 |  |  |  |  |  |  |
| 242242325a | Spine Refusrbish FY14 | 261d | 2013-12-03 | 2014-12-22 | 242242325 |  |  |  |  | 212d | 0d | 8/5 M-F w/JLAB Holidays ReBaseline | MECH TECH [18.58 h] | 879.21 |  |  | 0 | IN | ELOUADRHIRI L | 1 | 1 | APP | H | LATIFA E | 12-007 |  |  |  | 242242325 |  | 13-002F | PE |  | 13-015 | PR | 14-001 | 12-027 | 12-054 |  |  |  |  |  |  |
| 242242137 | Glue Procurement | 74d | 2013-12-05 | 2014-03-31 | 9-140M FS+45d |  |  |  |  | 397d | 265d | 8/5 M-F w/JLAB Holidays ReBaseline | SCIENTIST [4 h]; SUPPLIES & MATERIALS | 2,381.03 |  |  | 0 | IN | ELOUADRHIRI L | 1 | 1 | APP | D | LATIFA E | 12-007 | 12-053 |  |  | 242242137 |  | 13-002F | PE | PE | 13-015 | PR | 14-001 |  |  |  |  |  |  |  |  |
| 242242107a | Al/Mg Laxon/Acrylic Re-Coating Test Procurement Labor FY14 | 30d | 2013-12-10 | 2014-01-31 | 242242107 |  |  |  |  | 193d | 0d | 8/5 M-F w/JLAB Holidays ReBaseline | SCIENTIST [16 h] | 1,202.88 |  |  | 0 | IN | ELOUADRHIRI L | 1 | 1 | APP | H | LATIFA E | 12-007 |  |  |  | 242242107 |  | 13-002F | PE |  | 13-015 | PR | 14-001 |  | 12-054 |  |  |  |  |  |  |
| 242242280a | Frame Support FY14 | 46d | 2013-12-13 | 2014-02-27 | 242242280 |  |  |  |  | 419d | 287d | 8/5 M-F w/JLAB Holidays ReBaseline | MECH TECH [13.38 h] | 633.14 |  |  | 0 | IN | ELOUADRHIRI L | 1 | 1 | APP | H | LATIFA E | 12-007 |  |  |  | 242242280 |  | 13-002F | PE |  | 13-015 | PR | 14-001 | 12-027 | 12-054 |  |  |  |  |  |  |
| 242242152b | Window Procurement -Labor FY14 | 119d | 2013-12-17 | 2014-06-13 | 242242152a |  |  |  |  | 132d | 0d | 8/5 M-F w/JLAB Holidays ReBaseline | SCIENTIST [27.4 h] | 2,059.93 |  |  | 0 | IN | ELOUADRHIRI L | 1 | 1 | APP | D | LATIFA E | 12-007 |  |  |  | 242242152 |  | 13-002F | PE |  | 13-015 | PR | 14-001 |  | 12-054 |  |  |  | PE |  |  |
| 242242155 | Walls Manufacturing and Installation | 39d | 2013-12-17 | 2014-02-20 | 242242145aa FS-6d, 242242145a FS-6d |  |  |  |  | 424d | 292d | 8/5 M-F w/JLAB Holidays ReBaseline | SCIENTIST [8 h]; MECH TECH [40 h] | 2,494.24 |  |  | 0 | IN | ELOUADRHIRI L | 1 | 1 | APP | H | LATIFA E | 12-007 |  |  |  | 242242155 |  | 13-002F | PE |  | 13-015 | PR | 14-001 |  | 12-054 |  |  |  |  |  |  |
| 242242076 | Support Frame Fabrication for 1S in TED | 61d | 2014-01-03 | 2014-03-31 | 9-140M FS+60d |  |  |  |  | 397d | 265d | 8/5 M-F w/JLAB Holidays ReBaseline | SUPPLIES & MATERIALS; MECH TECH [40 h] | 2,924.7 |  |  | 0 | IN | ELOUADRHIRI L | 1 | 1 | APP | D | LATIFA E | 12-007 |  |  |  | 242242076 |  | 13-002F | PE | PE | 13-015 | PR | 14-001 |  | 12-054F |  |  |  |  |  |  |
| 242242077 | Infrastructure Consumables | 162d | 2014-01-03 | 2014-08-21 | 9-140M FS+60d |  |  |  |  | 296d | 164d | 8/5 M-F w/JLAB Holidays ReBaseline | SUPPLIES & MATERIALS | 16,716.78 |  |  | 0 | IN | ELOUADRHIRI L | 1 | 1 | APP | D | LATIFA E | 12-007 |  |  |  | 242242077 |  | 13-002F |  | PE | 13-015 | PR | 14-001 |  | 12-054F |  |  |  |  |  |  |
| 242242090 | Dimensions check of Elliptical/Hyperbolic mirrors | 188d | 2014-01-03 | 2014-09-29 | 9-140M FS+60d, 242242085 FS-220d |  |  |  |  | 270d | 138d | 8/5 M-F w/JLAB Holidays ReBaseline | SCIENTIST [67.2 h]; VISTNG USERS [224 h] | 9,664.26 |  |  | 0 | IN | ELOUADRHIRI L | 1 | 1 | APP | U | LATIFA E | 12-007 |  |  |  | 242242090 |  | 13-002F | PE |  | 13-015 | PR | 14-001 |  | 12-054F |  |  |  |  |  |  |
| 242242255 | Procurement Sagging Test Tools | 52d | 2014-01-03 | 2014-03-18 | 242242245 FS-42d |  |  |  |  | 383d | 0d | 8/5 M-F w/JLAB Holidays ReBaseline | SCIENTIST [8 h] | 601.44 |  |  | 0 | IN | ELOUADRHIRI L | 1 | 1 | APP | D | LATIFA E | 12-007 |  |  |  | 242242255 |  | 13-002F | PE |  | 13-015 | PR | 14-001 | 12-027 | 12-054 |  |  |  |  |  |  |
| 242242260 | Manufacture Sagging Test Tools | 52d | 2014-01-03 | 2014-03-18 | 242242245 FS-42d |  |  |  |  | 383d | 0d | 8/5 M-F w/JLAB Holidays ReBaseline | MECH TECH [40 h] | 1,892.8 |  |  | 0 | IN | ELOUADRHIRI L | 1 | 1 | APP | H | LATIFA E | 12-007 |  |  |  | 242242260 |  | 13-002F | PE |  | 13-015 | PR | 14-001 | 12-027 | 12-054 |  |  |  |  |  |  |
| 242242055 | Alignment Tool and Lasers Installation | 87d | 2014-01-09 | 2014-05-12 | 242242045b FS-52d, 242242045 FS-52d, 242242050a FS-30d, 242242050 FS-30d |  |  |  |  | 177d | 0d | 8/5 M-F w/JLAB Holidays ReBaseline | MECH TECH [40 h]; SCIENTIST [8 h] | 2,494.24 |  |  | 0 | IN | ELOUADRHIRI L | 1 | 1 | APP | S | LATIFA E | 12-007 |  |  |  | 242242055 |  | 13-002F | PE |  | 13-015 | PR | 14-001 | 12-027 |  |  |  |  |  |  | ST |
| 242242300 | Rear Brace Manufacture | 74d | 2014-01-16 | 2014-04-30 | 242242095a FS+16d, 242242095 FS+16d |  |  |  |  | 267d | 0d | 8/5 M-F w/JLAB Holidays ReBaseline | MECH TECH [16 h]; SUPPLIES & MATERIALS | 1,273.07 |  |  | 0 | IN | ELOUADRHIRI L | 1 | 1 | APP | H | LATIFA E | 12-007 |  |  |  | 242242300 |  | 13-002F | PE | PE | 13-015 | PR | 14-001 | 12-027 | 12-054 |  |  |  |  |  |  |
| 242242320 | Nose Extension Installation | 200d | 2014-01-16 | 2014-10-28 | 9-140M FS+69d |  |  |  |  | 233d | 21d | 8/5 M-F w/JLAB Holidays ReBaseline | MECH TECH [8 h] | 378.56 |  |  | 0 | IN | ELOUADRHIRI L | 1 | 1 | APP | H | LATIFA E | 12-007 |  |  |  | 242242320 |  | 13-002F | PE |  | 13-015 | PR | 14-001 | 12-027 | 12-054 |  |  |  |  |  |  |
| 242242230 | PMT Installation | 219d | 2014-01-21 | 2014-11-26 | 242242031a FS-100d, 242242031 FS-100d, 242242310 FS-150d |  |  |  |  | 231d | 0d | 8/5 M-F w/JLAB Holidays ReBaseline | SCIENTIST [4 h]; MECH TECH [16 h] | 1,057.84 |  |  | 0 | IN | ELOUADRHIRI L | 1 | 1 | APP | H | LATIFA E | 12-007 |  |  |  | 242242230 |  | 13-002F | PE |  | 13-015 | PR | 14-001 | 12-027 | 12-054 |  |  |  |  |  |  |
| 242242365 | Sector 3 Box Refurbish | 21d | 2014-01-23 | 2014-02-20 | 242242360 FS-163d |  |  |  |  | 291d | 108d | 8/5 M-F w/JLAB Holidays ReBaseline | MECH TECH [288 h] | 13,628.16 |  |  | 0 | IN | ELOUADRHIRI L | 1 | 1 | APP | S | LATIFA E | 12-007 |  |  |  | 242242365 |  | 13-002F | PE |  | 13-015 | PR | 14-001 |  | 12-054F |  |  |  |  |  | ST |
| 242242108 | Lexan/Acrylic/Over- Coating Procurement (all sectors) | 241d | 2014-01-31 | 2015-01-22 | 242242107a FS-1d, 242242107 FS-1d |  |  |  |  | 198d | 66d | 8/5 M-F w/JLAB Holidays ReBaseline | SCIENTIST [44 h]; SUPPLIES & MATERIALS | 5,371.72 |  |  | 0 | IN | ELOUADRHIRI L | 1 | 1 | APP | U | LATIFA E | 12-007 |  |  |  | 242242108 |  | 13-002F | PE | PE | 13-015 | PR | 14-001 |  | 12-054 |  |  |  | PE |  |  |
| 242242092 | Al/Mg Deposit Procurement WC | 245d | 2014-02-03 | 2015-01-29 | 242242107 FS-13d, 242242107a |  |  |  |  | 193d | 61d | 8/5 M-F w/JLAB Holidays ReBaseline | SCIENTIST [88 h]; PROCUREMENT<$50K 60 NO ESCALATION FY15; PROCUREMENT>$50K 69 NO ESCALATION FY15 | 59,856.72 |  |  | 0 | IN | ELOUADRHIRI L | 1 | 1 | APP | U | LATIFA E | 12-007 |  | 100 |  | 242242092 |  | 13-002F | PE |  | 13-015 | PR | 14-001 |  | 12-054F | 53240.88 | 0 | 0 | PE |  |  |
| 242242110 | Al/Mg Deposit Procurement | 259d | 2014-02-07 | 2015-02-24 | 242242105 FS+23d, 242242105a |  |  |  |  | 167d | 0d | 8/5 M-F w/JLAB Holidays ReBaseline | PROCUREMENT<$50K 60 NO ESCALATION FY15; PROCUREMENT>$50K 69 NO ESCALATION FY15 | 53,240.88 |  |  | 0 | IN | ELOUADRHIRI L | 1 | 1 | APP | D | LATIFA E | 12-007 |  | 100 |  | 242242110 |  | 13-002F |  |  | 13-015 | PR | 14-001 |  | 12-054 | 53240.88 | 0 | 0 | PE |  |  |
| 242242040 | Wavelength Shifting Procurement | 203d | 2014-02-11 | 2014-11-25 | 242242036 FS+50d, 242242036a FS+50d |  |  |  |  | 229d | 97d | 8/5 M-F w/JLAB Holidays ReBaseline | PROCUREMENT<$50K 60 NO ESCALATION FY15; PROCUREMENT>$50K 69 NO ESCALATION FY15 | 61,914 |  |  | 0 | IN | ELOUADRHIRI L | 1 | 1 | APP | D | LATIFA E | 12-007 |  | 100 |  | 242242040 |  | 13-002F |  |  | 13-015 | PR | 14-001 |  |  | 61914 | 0 | 0 | PE |  |  |
| 242242315 | Patch Panel Installation | 185d | 2014-02-11 | 2014-10-30 | 242242230 FS-204d |  |  |  |  | 231d | 19d | 8/5 M-F w/JLAB Holidays ReBaseline | MECH TECH [8 h]; SCIENTIST [4 h] | 679.28 |  |  | 0 | IN | ELOUADRHIRI L | 1 | 1 | APP | H | LATIFA E | 12-007 |  |  |  | 242242315 |  | 13-002F | PE |  | 13-015 | PR | 14-001 | 12-027 | 12-054 |  |  |  |  |  |  |
| 242242169 | New Patch Panel Fabrication | 120d | 2014-02-11 | 2014-07-31 | 242242161 FS-48.5d |  |  |  |  | 311.5d | 179.5d | 8/5 M-F w/JLAB Holidays ReBaseline | MECH TECH [64 h] | 3,028.48 |  |  | 0 | IN | ELOUADRHIRI L | 1 | 1 | APP | D | LATIFA E | 12-007 | 12-053 |  |  | 242242169 |  | 13-002F | PE |  | 13-015 | PR | 14-001 |  |  |  |  |  |  |  |  |
| 242242163 | Divider Modifications Procurement | 220d | 2014-02-12 | 2014-12-23 | 242242162 |  |  |  |  | 226d | 0d | 8/5 M-F w/JLAB Holidays ReBaseline | SCIENTIST [32 h]; PROCUREMENT<$50K 60 NO ESCALATION FY15 | 6,017.41 |  |  | 0 | IN | ELOUADRHIRI L | 1 | 1 | APP | D | LATIFA E | 12-007 |  | 100 |  | 242242163 |  | 13-002F | PE |  | 13-015 | PR | 14-001 |  | 12-054 | 3611.65 | 0 | 0 | PE |  |  |
| 242242164 | Divider Modifications Implementation | 205d | 2014-02-12 | 2014-12-02 | 242242163 FS-220d |  |  |  |  | 226d | 94d | 8/5 M-F w/JLAB Holidays ReBaseline | ELEC TECH [160 h]; SCIENTIST [44 h] | 10,826.32 |  |  | 0 | IN | ELOUADRHIRI L | 1 | 1 | APP | U | LATIFA E | 12-007 |  |  |  | 242242164 |  | 13-002F | PE |  | 13-015 | PR | 14-001 |  | 12-054 |  |  |  |  |  |  |
| 242242390 | Sector 4 Box Refurbish | 27d | 2014-03-05 | 2014-04-10 | 242242385 FS-170d |  |  |  |  | 299d | 116d | 8/5 M-F w/JLAB Holidays ReBaseline | MECH TECH [288 h] | 13,628.16 |  |  | 0 | IN | ELOUADRHIRI L | 1 | 1 | APP | S | LATIFA E | 12-007 |  |  |  | 242242390 |  | 13-002F | PE |  | 13-015 | PR | 14-001 |  | 12-054F |  |  |  |  |  | ST |
| 242242270 | Sagging Test | 23d | 2014-03-19 | 2014-04-18 | 242242260, 242242255 |  |  |  |  | 383d | 251d | 8/5 M-F w/JLAB Holidays ReBaseline | MECH TECH [56 h]; SCIENTIST [12 h] | 3,552.08 |  |  | 0 | IN | ELOUADRHIRI L | 1 | 1 | APP | S | LATIFA E | 12-007 |  |  |  | 242242270 |  | 13-002F | PE |  | 13-015 | PR | 14-001 | 12-027 | 12-054 |  |  |  |  |  | ST |
| 242242305 | Rear Brace Installation | 137d | 2014-03-20 | 2014-10-01 | 242242300 FS-30d |  |  |  |  | 267d | 35d | 8/5 M-F w/JLAB Holidays ReBaseline | MECH TECH [32 h] | 1,514.24 |  |  | 0 | IN | ELOUADRHIRI L | 1 | 1 | APP | H | LATIFA E | 12-007 |  |  |  | 242242305 |  | 13-002F | PE |  | 13-015 | PR | 14-001 | 12-027 | 12-054 |  |  |  |  |  |  |
| 242242205 | Mirrors Laser Alignments | 222d | 2014-03-28 | 2015-02-20 | 242242095a, 242242095, 242242055 FS-32d |  |  |  |  | 177d | 45d | 8/5 M-F w/JLAB Holidays ReBaseline | PD UNIV STUDNT [160 h]; MECH TECH [120 h]; SCIENTIST [104 h]; VISTNG USERS [160 h] | 18,609.12 |  |  | 0 | IN | ELOUADRHIRI L | 1 | 1 | APP | S | LATIFA E | 12-007 |  |  |  | 242242205 |  | 13-002F | PE |  | 13-015 | PR | 14-001 | 12-027 |  |  |  |  |  |  | ST |
| 242242115 | Installation of Elliptical mirrors | 227d | 2014-04-04 | 2015-03-06 | 242242110 FS-219d |  |  |  |  | 167d | 35d | 8/5 M-F w/JLAB Holidays ReBaseline | MECH TECH [16 h]; SCIENTIST [4 h] | 1,057.84 |  |  | 0 | IN | ELOUADRHIRI L | 1 | 1 | APP | H | LATIFA E | 12-007 |  |  |  | 242242115 |  | 13-002F | PE |  | 13-015 | PR | 14-001 |  | 12-054 |  |  |  |  |  |  |
| 242242415 | Sector 5 Box Refurbish | 22d | 2014-04-16 | 2014-05-15 | 242242410 FS-172d |  |  |  |  | 300d | 117d | 8/5 M-F w/JLAB Holidays ReBaseline | MECH TECH [256 h] | 12,113.92 |  |  | 0 | IN | ELOUADRHIRI L | 1 | 1 | APP | S | LATIFA E | 12-007 |  |  |  | 242242415 |  | 13-002F | PE |  | 13-015 | PR | 14-001 |  | 12-054F |  |  |  |  |  | ST |

Notes:
- 242242220a: Steps: HV slow control access; DAQ setup; Software to control HV; SPE Histos Software
- 242242220aa: Steps: HV slow control access; DAQ setup; Software to control HV; SPE Histos Software
- 242242222: Steps: HV slow control access; DAQ setup; Software to control HV; SPE Histos Software
- 242242222a: Steps: HV slow control access; DAQ setup; Software to control HV; SPE Histos Software
- 242242085: Steps: Visual Inspection of Mirrors; Sample Mirrors Reflectivity Tests
- 242242340: Steps: Box Frame Support; Cut Line Mark; Box Cut; Wall Cut; Box Plates Fit; Patch Panel Fit; Rear Brace; Nose Installation; PMT, Mirrors Holes; Spine Refurbish; Mount PMT, Mirrors, WC
- 242242055: Steps: Tool assembly; Laser table assembly; Laser system assembly; Sector mount on tool
- 242242365: Steps: Box Frame Support; Cut Line Mark; Box Cut; Wall Cut; Box Plates Fit; Patch Panel Fit; Rear Brace; Nose Installation; PMT, Mirrors Holes; Spine Refurbish; Mount PMT, Mirrors, WC
- 242242390: Steps: Box Frame Support; Cut Line Mark; Box Cut; Wall Cut; Box Plates Fit; Patch Panel Fit; Rear Brace; Nose Installation; PMT, Mirrors Holes; Spine Refurbish; Mount PMT, Mirrors, WC
- 242242270: Steps: Laser Mount on Box; Reference Mount on Box; Box rotation and reference check
- 242242205: Steps: Laser Setup; Laser/Box Survey; Elliptical Alignment; Hyperbolic Alignment
- 242242415: Steps: Box Frame Support; Cut Line Mark; Box Cut; Wall Cut; Box Plates Fit; Patch Panel Fit; Rear Brace; Nose Installation; PMT, Mirrors Holes; Spine Refurbish; Mount PMT, Mirrors, WC

| ID | Activity | Type | Duration | Start | Finish | Predecessors | Total float | Free float | Calendar | Resources | Cost | Original Activity ID Rebaseline | MONTHLY EV COST | PHAS - Project Phase | RESP - Responsibility | STRT%COMP for CM EVM | FNSH%COMP for CM EVM | Advance Purchase Plan > 500K | EVMS Reporting Codes | CAM RESPONSIBLE | CR 12-007 | CR 12-054 | CR 13-002 | BOE Labor | CR 13-015 | Post Rebaseline | CR 14-001 | CR 12-027 | Activities with Steps | CR 12-053 | Remaining Material Cost Based on % Compl | Claimed Material Cost Based on % Complet | Initial Claimed Material Calc | Claimed Material Divider | BOE Procurement |
| --- | --- | --- | --- | --- | --- | --- | --- | --- | --- | --- | --- | --- | --- | --- | --- | --- | --- | --- | --- | --- | --- | --- | --- | --- | --- | --- | --- | --- | --- | --- | --- | --- | --- | --- | --- |
| 242242350 | Sector 2 Mirrors Alignment |  | 50d | 2014-04-17 | 2014-06-26 | 242242340 FS+80d | 183d | 0d | 8/5 M-F w/JLAB Holidays ReBaseline | MECH TECH [80 h] | 3,785.6 | 242242350 | 0 | IN | ELOUADRHIRI L | 1 | 1 | APP | H | LATIFA E | 12-007 | 12-054F | 13-002F | PE | 13-015 | PR | 14-001 |  |  |  |  |  |  |  |  |
| 242242330 | Gas Line Refurbish |  | 165d | 2014-04-29 | 2014-12-22 | 242242325 FS-165d, 242242325a FS-165d | 212d | 80d | 8/5 M-F w/JLAB Holidays ReBaseline | MECH TECH [20 h]; SCIENTIST [4 h] | 1,247.12 | 242242330 | 0 | IN | ELOUADRHIRI L | 1 | 1 | APP | H | LATIFA E | 12-007 | 12-054 | 13-002F | PE | 13-015 | PR | 14-001 | 12-027 |  |  |  |  |  |  |  |
| 242242235 | Windows Installation 6 sectors |  | 197d | 2014-05-16 | 2015-03-06 | 242242230 FS-252d, 242242152b FS-20d, 242242152 FS-20d | 132d | 0d | 8/5 M-F w/JLAB Holidays ReBaseline | MECH TECH [200 h] | 9,464 | 242242235 | 0 | IN | ELOUADRHIRI L | 1 | 1 | APP | U | LATIFA E | 12-007 | 12-054 | 13-002F | PE | 13-015 | PR | 14-001 | 12-027 |  |  |  |  |  |  |  |
| 242242440 | Sector 6 Box Refurbish |  | 16d | 2014-05-29 | 2014-06-19 | 242242435 FS-158d | 298d | 115d | 8/5 M-F w/JLAB Holidays ReBaseline | MECH TECH [256 h] | 12,113.92 | 242242440 | 0 | IN | ELOUADRHIRI L | 1 | 1 | APP | S | LATIFA E | 12-007 | 12-054F | 13-002F | PE | 13-015 | PR | 14-001 |  | ST |  |  |  |  |  |  |
| 242242223 | Online HV Matching Test |  | 110d | 2014-06-09 | 2014-11-11 | 242242220aa FS-15d, 242242222a FS-15d, 242242220a FS-15d, 242242222 FS-15d | 239d | 0d | 8/5 M-F w/JLAB Holidays ReBaseline | SCIENTIST [48 h] | 3,608.64 | 242242223 | 0 | IN | ELOUADRHIRI L | 1 | 1 | APP | S | LATIFA E | 12-007 |  | 13-002F | PE | 13-015 | PR | 14-001 |  | ST | 12-053 |  |  |  |  |  |
| 242242355 | Sector 2 Windows Installation |  | 11d | 2014-07-02 | 2014-07-17 | 242242350 FS+3d | 183d | 0d | 8/5 M-F w/JLAB Holidays ReBaseline | MECH TECH [40 h] | 1,892.8 | 242242355 | 0 | IN | ELOUADRHIRI L | 1 | 1 | APP | H | LATIFA E | 12-007 | 12-054F | 13-002F | PE | 13-015 | PR | 14-001 |  |  |  |  |  |  |  |  |
| 242242375 | Sector 3 Mirrors Alignment |  | 26d | 2014-07-24 | 2014-08-28 | 242242355 FS+4d, 242242365 FS-1d | 183d | 0d | 8/5 M-F w/JLAB Holidays ReBaseline | MECH TECH [80 h] | 3,785.6 | 242242375 | 0 | IN | ELOUADRHIRI L | 1 | 1 | APP | H | LATIFA E | 12-007 | 12-054F | 13-002F | PE | 13-015 | PR | 14-001 |  |  |  |  |  |  |  |  |
| 242242360 | Sector 2 Gas Leaks Checks |  | 26d | 2014-08-06 | 2014-09-11 | 242242355 FS+13d | 291d | 0d | 8/5 M-F w/JLAB Holidays ReBaseline | MECH TECH [48 h] | 2,271.36 | 242242360 | 0 | IN | ELOUADRHIRI L | 1 | 1 | APP | H | LATIFA E | 12-007 | 12-054F | 13-002F | PE | 13-015 | PR | 14-001 |  |  |  |  |  |  |  |  |
| 242242240 | Gas Leak Check 6 sectors |  | 174d | 2014-08-08 | 2015-04-24 | 242242235 FS-139d | 132d | 0d | 8/5 M-F w/JLAB Holidays ReBaseline | MECH TECH [120 h]; SCIENTIST [110 h] | 13,948.2 | 242242240 | 0 | IN | ELOUADRHIRI L | 1 | 1 | APP | S | LATIFA E | 12-007 | 12-054 | 13-002F | PE | 13-015 | PR | 14-001 | 12-027 | ST |  |  |  |  |  |  |
| 242242380 | Sector 3 Windows Installation |  | 14d | 2014-08-29 | 2014-09-18 | 242242375 | 183d | 0d | 8/5 M-F w/JLAB Holidays ReBaseline | MECH TECH [40 h] | 1,892.8 | 242242380 | 0 | IN | ELOUADRHIRI L | 1 | 1 | APP | H | LATIFA E | 12-007 | 12-054F | 13-002F | PE | 13-015 | PR | 14-001 |  |  |  |  |  |  |  |  |
| 242242400 | Sector 4 Mirrors Alignment |  | 26d | 2014-09-25 | 2014-10-30 | 242242390, 242242380 FS+4d | 183d | 0d | 8/5 M-F w/JLAB Holidays ReBaseline | MECH TECH [80 h] | 3,785.6 | 242242400 | 0 | IN | ELOUADRHIRI L | 1 | 1 | APP | H | LATIFA E | 12-007 | 12-054F | 13-002F | PE | 13-015 | PR | 14-001 |  |  |  |  |  |  |  |  |
| 242242170 | Patch Panel Connectors Procurement |  | 77d | 2014-10-01 | 2015-01-30 | 9-155M | 192d | 60d | 8/5 M-F w/JLAB Holidays ReBaseline | SCIENTIST [28 h]; PROCUREMENT<$50K 60 | 14,647.58 | 242242170 | 0 | IN | ELOUADRHIRI L | 1 | 1 | APP | D | LATIFA E | 12-007 |  | 13-002F | PE | 13-015 | PR | 14-001 |  |  | 12-053 | 12542.54 | 0 | 0 | 100 | PE |
| 242242185 | Procure Gas Line |  | 33d | 2014-10-01 | 2014-11-14 | 9-155M | 215d | 0d | 8/5 M-F w/JLAB Holidays ReBaseline | SCIENTIST [8 h]; PROCUREMENT<$50K 60 | 12,984.24 | 242242185 | 0 | IN | ELOUADRHIRI L | 1 | 1 | APP | D | LATIFA E | 12-007 |  | 13-002F | PE | 13-015 | PR | 14-001 |  |  |  | 12382.8 | 0 | 0 | 100 | PE |
| 242242215 | Installation of FADC, DAQ, Computer, Electronics for 1 Sector |  | 42d | 2014-10-01 | 2014-12-01 | 9-155M | 227d | 95d | 8/5 M-F w/JLAB Holidays ReBaseline | SCIENTIST [8 h] | 601.44 | 242242215 | 0 | IN | ELOUADRHIRI L | 1 | 1 | APP | H | LATIFA E | 12-007 |  | 13-002F | PE | 13-015 | PR | 14-001 |  |  |  |  |  |  |  |  |
| 242242385 | Sector 3 Gas Leaks Checks |  | 22d | 2014-10-02 | 2014-10-31 | 242242380 FS+9d | 299d | 0d | 8/5 M-F w/JLAB Holidays ReBaseline | MECH TECH [40 h] | 1,892.8 | 242242385 | 0 | IN | ELOUADRHIRI L | 1 | 1 | APP | H | LATIFA E | 12-007 | 12-054F | 13-002F | PE | 13-015 | PR | 14-001 |  |  |  |  |  |  |  |  |
| 242242225 | Online Calibration Test |  | 24d | 2014-10-09 | 2014-11-11 | 242242220a, 242242222a, 242242222, 242242220aa, 242242223 FS-24d | 239d | 107d | 8/5 M-F w/JLAB Holidays ReBaseline | SCIENTIST [16 h] | 1,202.88 | 242242225 | 0 | IN | ELOUADRHIRI L | 1 | 1 | APP | H | LATIFA E | 12-007 |  | 13-002F | PE | 13-015 | PR | 14-001 |  |  |  |  |  |  |  |  |
| 242242405 | Sector 4 Windows Installation |  | 15d | 2014-10-31 | 2014-11-20 | 242242400 | 300d | 0d | 8/5 M-F w/JLAB Holidays ReBaseline | MECH TECH [40 h] | 1,892.8 | 242242405 | 0 | IN | ELOUADRHIRI L | 1 | 1 | APP | H | LATIFA E | 12-007 | 12-054F | 13-002F | PE | 13-015 | PR | 14-001 |  |  |  |  |  |  |  |  |
| 242242425 | Sector 5 Mirrors Alignment |  | 10d | 2014-10-31 | 2014-11-13 | 242242415, 242242400 | 183d | 0d | 8/5 M-F w/JLAB Holidays ReBaseline | MECH TECH [80 h] | 3,785.6 | 242242425 | 0 | IN | ELOUADRHIRI L | 1 | 1 | APP | H | LATIFA E | 12-007 | 12-054F | 13-002F | PE | 13-015 | PR | 14-001 |  |  |  |  |  |  |  |  |
| 242242190 | Install Gas Line (1S) |  | 10d | 2014-11-25 | 2014-12-10 | 242242185 FS+6d | 215d | 0d | 8/5 M-F w/JLAB Holidays ReBaseline | MECH TECH [20 h] | 946.4 | 242242190 | 0 | IN | ELOUADRHIRI L | 1 | 1 | APP | H | LATIFA E | 12-007 |  | 13-002F | PE | 13-015 | PR | 14-001 |  |  |  |  |  |  |  |  |
| 242242410 | Sector 4 Gas Leaks Checks |  | 13d | 2014-12-02 | 2014-12-18 | 242242405 FS+5d | 300d | 0d | 8/5 M-F w/JLAB Holidays ReBaseline | MECH TECH [40 h] | 1,892.8 | 242242410 | 0 | IN | ELOUADRHIRI L | 1 | 1 | APP | H | LATIFA E | 12-007 | 12-054F | 13-002F | PE | 13-015 | PR | 14-001 |  |  |  |  |  |  |  |  |
| 242242430 | Sector 5 Windows Installation |  | 13d | 2014-12-02 | 2014-12-18 | 242242425 FS+10d | 298d | 0d | 8/5 M-F w/JLAB Holidays ReBaseline | MECH TECH [40 h] | 1,892.8 | 242242430 | 0 | IN | ELOUADRHIRI L | 1 | 1 | APP | H | LATIFA E | 12-007 | 12-054F | 13-002F | PE | 13-015 | PR | 14-001 |  |  |  |  |  |  |  |  |
| 242242450 | Sector 6 Mirrors Alignment |  | 13d | 2014-12-02 | 2014-12-18 | 242242440 FS-2d, 242242425 FS+10d | 183d | 0d | 8/5 M-F w/JLAB Holidays ReBaseline | MECH TECH [80 h] | 3,785.6 | 242242450 | 0 | IN | ELOUADRHIRI L | 1 | 1 | APP | H | LATIFA E | 12-007 | 12-054F | 13-002F | PE | 13-015 | PR | 14-001 |  |  |  |  |  |  |  |  |
| 242242195 | Gas Line Quality Control |  | 5d | 2014-12-11 | 2014-12-17 | 242242190 | 215d | 83d | 8/5 M-F w/JLAB Holidays ReBaseline | MECH TECH [8 h] | 378.56 | 242242195 | 0 | IN | ELOUADRHIRI L | 1 | 1 | APP | H | LATIFA E | 12-007 |  | 13-002F | PE | 13-015 | PR | 14-001 |  |  |  |  |  |  |  |  |
| 242242435 | Sector 5 Gas Leaks Checks |  | 16d | 2014-12-19 | 2015-01-22 | 242242430 | 298d | 0d | 8/5 M-F w/JLAB Holidays ReBaseline | MECH TECH [40 h] | 1,892.8 | 242242435 | 0 | IN | ELOUADRHIRI L | 1 | 1 | APP | H | LATIFA E | 12-007 | 12-054F | 13-002F | PE | 13-015 | PR | 14-001 |  |  |  |  |  |  |  |  |
| 242242455 | Sector 6 Windows Installation |  | 16d | 2014-12-19 | 2015-01-22 | 242242450 | 183d | 0d | 8/5 M-F w/JLAB Holidays ReBaseline | MECH TECH [40 h] | 1,892.8 | 242242455 | 0 | IN | ELOUADRHIRI L | 1 | 1 | APP | H | LATIFA E | 12-007 | 12-054F | 13-002F | PE | 13-015 | PR | 14-001 |  |  |  |  |  |  |  |  |
| 242242460 | Sector 6 Gas Leaks Checks |  | 16d | 2015-01-22 | 2015-02-12 | 242242455 FS-1d | 183d | 51d | 8/5 M-F w/JLAB Holidays ReBaseline | MECH TECH [40 h] | 1,892.8 | 242242460 | 0 | IN | ELOUADRHIRI L | 1 | 1 | APP | H | LATIFA E | 12-007 | 12-054F | 13-002F | PE | 13-015 | PR | 14-001 |  |  |  |  |  |  |  |  |
| 242242500M | LTCC Complete | milestone | 0d | 2015-04-24 | 2015-04-24 | 242242335, 242242076, 242242077, 242242090, 242242169, 242242280, 242242225, 242242092, 242242165b, 242242295a, 242242036, 242242040, 242242137, 242242280a, 242242460, 242242295, 242242330, 242242036a, 242242340, 242242030, 242242164, 242242108, 242242155, 242242031, 242242161, 242242170, 242242107, 242242115, 242242031a, 242242195, 242242215, 242242240, 242242270, 242242095, 242242205 | 132d | 0d | 8/5 M-F w/JLAB Holidays ReBaseline |  |  | 242242500M | 0 | IN | ELOUADRHIRI L | 1 | 1 | APP | M | LATIFA E | 12-007 | 12-054 | 13-002F |  | 13-015 | PR |  | 12-027 |  |  |  |  |  |  |  |

Notes:
- 242242440: Steps: Box Frame Support; Cut Line Mark; Box Cut; Wall Cut; Box Plates Fit; Patch Panel Fit; Rear Brace; Nose Installation; PMT, Mirrors Holes; Spine Refurbish; Mount PMT, Mirrors, WC
- 242242223: Steps: 1 Full sector HC connection; DAQ setup
- 242242240: Steps: Nitrogen Fill 1/2"; Freon Fill; Snoop

| ID | WBS | Activity | Duration | Start | Finish | Predecessors | Complete | Remaining | Planned start | Planned finish | Total float | Free float | Calendar | Resources | Cost | Actual cost | Calculated Remaining Total Cost | MONTHLY EV COST | PHAS - Project Phase | RESP - Responsibility | STRT%COMP for CM EVM | FNSH%COMP for CM EVM | EVMS Reporting Codes | CAM RESPONSIBLE | CR 12-007 | CR 12-027 | CR 12-054 | MARCH!!! | Remaining Material Cost Based on % Compl | Claimed Material Cost Based on % Complet | Initial Claimed Material Calc | Claimed Material Divider | CR 11-026 | CR 12-040 | CR 08-016 | CR 09-012 | ReBaseline Actuals Adjustment | Original Activity ID Rebaseline | CR 13-002 | BOE Procurement | CR 13-015 | Post Rebaseline | Obligated Prior to Rebaseline | CR 14-001 | BOE Labor |
| --- | --- | --- | --- | --- | --- | --- | --- | --- | --- | --- | --- | --- | --- | --- | --- | --- | --- | --- | --- | --- | --- | --- | --- | --- | --- | --- | --- | --- | --- | --- | --- | --- | --- | --- | --- | --- | --- | --- | --- | --- | --- | --- | --- | --- | --- |
|  | 3 | **1.4.2.3 COMPUTING** |  | 2011-04-01 | 2015-08-12 |  |  |  |  |  |  |  |  |  |  |  |  |  |  |  |  |  |  |  |  |  |  |  |  |  |  |  |  |  |  |  |  |  |  |  |  |  |  |  |  |
|  | 1 | **1.4.2.3.1 TRIGGER SYSTEM (Scintillators)** |  | 2011-11-01 | 2015-04-28 |  |  |  |  |  |  |  |  |  |  |  |  |  |  |  |  |  |  |  |  |  |  |  |  |  |  |  |  |  |  |  |  |  |  |  |  |  |  |  |  |
| 14231055 |  | SD procurement prep | 105d | 2011-11-01 A | 2012-04-09 A | 9-120M | 100% |  |  |  |  |  |  | SCIENTIST [40 h] | 2,824.4 | 2,824.4 | 0 | 2824.4 | IN | ELOUADRHIRI L | 1 | 1 | H | LATIFA E | 12-007 |  |  |  |  |  |  |  |  |  |  |  |  |  |  |  |  |  |  |  |  |
| 14231015 |  | SSP single board tests | 11d | 2011-12-03 A | 2011-12-19 A | 9-120M FS+41d | 100% |  | 2011-12-05 | 2011-12-19 |  |  |  | SCIENTIST [80 h] | 5,648.8 | 5,648.8 | 0 | 5648.8 | IN | ELOUADRHIRI L | 1 | 1 | H | LATIFA E | 12-007 | 12-027F |  |  |  |  |  |  |  |  |  |  |  |  |  |  |  |  |  |  |  |
| 14231035 |  | GTP single board tests | 266d | 2011-12-03 A | 2013-08-30 A | 9-120M FS+41d | 100% |  | 2011-12-05 | 2013-01-04 |  |  |  | SCIENTIST [80 h] | 5,690.75 | 5,743.8 | 2824.4 | 5648.8 | IN | ELOUADRHIRI L | 1 | 1 | H | LATIFA E | 12-007 | 12-027F | 12-054F | XX |  |  |  |  |  |  |  |  |  |  |  |  |  |  |  |  |  |
| 14231070 |  | TI procurement prep | 103d | 2011-12-12 A | 2012-05-14 A | 9-120M | 100% |  |  |  |  |  |  | SCIENTIST [40 h] | 2,824.4 | 2,824.4 | 0 | 2824.4 | IN | ELOUADRHIRI L | 1 | 1 | H | LATIFA E | 12-007 |  |  |  |  |  |  |  |  |  |  |  |  |  |  |  |  |  |  |  |  |
| 14231085 |  | TD procurement prep | 83d | 2011-12-12 A | 2012-04-16 A | 9-120M | 100% |  |  |  |  |  |  | SCIENTIST [40 h] | 2,824.4 | 2,824.4 | 0 | 2824.4 | IN | ELOUADRHIRI L | 1 | 1 | H | LATIFA E | 12-007 |  |  |  |  |  |  |  |  |  |  |  |  |  |  |  |  |  |  |  |  |
| 14231075 |  | TI procurement (52 boards) | 252d | 2012-03-12 A | 2012-12-17 A | 14231070 FS-50d | 100% |  | 2012-03-12 | 2013-03-15 |  |  |  | PROCUREMENT<$50K 60 NO ESCALATION FY13; PROCUREMENT>$50K 69 NO ESCALATION FY13 | 109,980 |  | 0 | 109980 | IN | ELOUADRHIRI L | 1 | 1 | D | LATIFA E | 12-007 |  |  |  | 0 | 109980 | 10998000 | 100 |  |  |  |  |  |  |  |  |  |  |  |  |  |
| 14231090 |  | TD procurement (10 boards) | 109d | 2012-03-12 A | 2012-08-13 A | 14231085 FS-50d | 100% |  |  |  |  |  |  | PROCUREMENT<$50K 60 NO ESCALATION FY13; PROCUREMENT>$50K 69 NO ESCALATION FY13 | 58,150 |  | 0 | 58150 | IN | ELOUADRHIRI L | 1 | 1 | D | LATIFA E | 12-007 |  |  |  | 0 | 58150 | 5815000 | 100 |  |  |  |  |  |  |  |  |  |  |  |  |  |
| 14231100 |  | TS single board tests | 179d | 2012-04-16 A | 2012-12-17 A | 9-120M FS+80d | 100% |  | 2012-04-16 | 2013-01-04 |  |  |  | SCIENTIST [80 h] | 5,711.15 | 5,705.64 | 0 | 5648.8 | IN | ELOUADRHIRI L | 1 | 1 | H | LATIFA E | 12-007 |  |  |  |  |  |  |  |  |  |  |  |  |  |  |  |  |  |  |  |  |
| 14231065 |  | SD testing of 24 boards | 123d | 2012-04-23 A | 2012-10-15 A | 14231060 FS-160d | 100% |  |  |  |  |  |  | SCIENTIST [80 h] | 5,664.9 | 5,664.9 | 0 | 3972.3272 | IN | ELOUADRHIRI L | 1 | 1 | U | LATIFA E | 12-007 |  |  |  |  |  |  |  |  |  |  |  |  |  |  |  |  |  |  |  |  |
| 14231060 |  | SD procurement (24 boards) | 93d | 2012-05-07 A | 2012-09-17 A | 14231055 | 100% |  |  |  |  |  |  | PROCUREMENT<$50K 60 NO ESCALATION FY13 | 18,240 |  | 0 | 18240 | IN | ELOUADRHIRI L | 1 | 1 | D | LATIFA E | 12-007 |  |  |  | 0 | 18240 | 1824000 | 100 |  |  |  |  |  |  |  |  |  |  |  |  |  |
| 14231020 |  | SSP procurement prep | 10d | 2012-06-05 A | 2012-06-18 A | 14231015 FS+20d, 9-120M FS+210d | 100% |  |  |  |  |  |  | SCIENTIST [40 h] | 2,824.4 | 2,824.4 | 0 | 2824.4 | IN | ELOUADRHIRI L | 1 | 1 | H | LATIFA E | 12-007 | 12-027F |  |  |  |  |  |  |  |  |  |  |  |  |  |  |  |  |  |  |  |
| 14231025 |  | SSP procurement (15 boards) | 150d | 2012-06-18 A | 2013-01-25 A | 14231020 | 100% |  |  |  |  |  |  | PROCUREMENT<$50K 60; PROCUREMENT>$50K 69 | 134,662.95 |  | 0 | 134662.95 | IN | ELOUADRHIRI L | 1 | 1 | D | LATIFA E | 12-007 | 12-027 |  | XX | 0 | 134662.95 | 13466295 | 100 |  |  |  |  |  |  |  |  |  |  |  |  |  |
| 14231005 |  | CTP Procurement Prep | 179d | 2012-07-02 A | 2012-12-17 A | 12223045, 9-120M, 12223040M | 100% |  | 2012-07-02 | 2013-03-22 |  |  |  | SCIENTIST [40 h] | 2,882.22 | 2,865.59 | 0 | 2824.4 |  | ELOUADRHIRI L | 1 | 1 | H | LATIFA E | 12-007 | 12-027F |  |  |  |  |  |  | 11-026 |  |  |  |  |  |  |  |  |  |  |  |  |
| 14231030 |  | SSP testing of 15 boards | 130d | 2013-02-15 A | 2013-08-30 A | 14231025, 18223005 FS-175d | 100% |  | 2013-08-16 | 2014-02-28 |  |  |  | SCIENTIST |  |  | 1375.08678 | 0 | IN | ELOUADRHIRI L | 1 | 1 | U | LATIFA E | 12-007 | 12-027 |  |  |  |  |  |  |  | 12-040 |  |  |  |  |  |  |  |  |  |  |  |
| 14231105 |  | TS procurement prep | 6d | 2013-02-15 A | 2013-08-30 A | 14231100, 9-130M | 100% |  | 2013-06-24 | 2013-07-01 |  |  |  | SCIENTIST [40 h] | 2,914.4 | 2,914.4 | 1457.2 | 2914.4 | IN | ELOUADRHIRI L | 1 | 1 | H | LATIFA E | 12-007 | 12-027 | 12-054 |  |  |  |  |  |  |  |  |  |  |  |  |  |  |  |  |  |  |
| 14231095 |  | TD testing of 10 boards | 59d | 2013-03-04 A | 2013-03-18 A | 14231090, 18223020 | 100% |  | 2013-04-01 | 2013-06-21 |  |  |  | SCIENTIST |  |  | 0 | 0 | IN | ELOUADRHIRI L | 1 | 1 | U | LATIFA E | 12-007 |  |  |  |  |  |  |  |  | 12-040 |  |  |  |  |  |  |  |  |  |  |  |
| 14231007 |  | CTP procurement (22 boards) | 80d | 2013-08-30 A | 2013-08-30 A | 9-130M, 9-120M FS+60d, 9-140M, 14231005 | 100% |  | 2013-10-01 | 2014-01-31 |  |  |  | PROCUREMENT<$50K 60; PROCUREMENT>$50K 69 | 140,410.63 |  | 140410.63 | 140410.63 |  | ELOUADRHIRI L | 1 | 1 | D | LATIFA E | 12-007 | 12-027 |  |  | 0 | 140410.63 | 14041063 | 100 | 11-026 |  | 08-016 | 09-012 |  |  |  |  |  |  |  |  |  |
| 14231040 |  | GTP procurement prep | 11d | 2013-08-30 A | 2013-08-30 A | 9-130M, 14231035 FS-20d | 100% |  | 2013-09-03 | 2013-09-17 |  |  |  | SCIENTIST [40 h] | 2,914.4 | 2,914.4 | 2914.4 | 2914.4 | IN | ELOUADRHIRI L | 1 | 1 | H | LATIFA E | 12-007 | 12-027 | 12-054 |  |  |  |  |  |  |  |  |  |  |  |  |  |  |  |  |  |  |
| 14231045 |  | GTP procurement (2 boards) | 9d | 2013-08-30 A | 2013-08-30 A | 9-130M, 14231040 FS+10d | 100% |  | 2013-10-02 | 2013-10-14 |  |  |  | PROCUREMENT<$50K 60 | 13,414.7 |  | 13414.7 | 13414.7 | IN | ELOUADRHIRI L | 1 | 1 | H | LATIFA E | 12-007 | 12-027 | 12-054 |  | 0 | 13414.7 | 1341470 | 100 |  |  |  |  |  |  |  |  |  |  |  |  |  |
| 14231125 |  | Re-Baseline Actuals Adjustment | 1d | 2013-08-30 A | 2013-08-30 A |  | 100% |  | 2013-09-03 | 2013-09-03 |  |  |  | PROCUREMENT>$50K 69 NO ESCALATION | -99,220.55 |  |  |  |  |  |  |  |  |  |  |  |  |  |  |  |  | 100 |  |  |  |  | ADJ |  |  |  |  |  |  |  |  |
| 24231000 |  | AVAGO QSFP OPTIC TRANS | 43d | 2013-09-03 A | 2013-12-05 | 9-130M FS+228d |  | 23d | 2013-10-01 | 2013-12-02 | 505d | 598d | 8/5 M-F w/JLAB Holidays ReBaseline | PROCUREMENT<$50K 60 NO ESCALATION FY14 | 1,017.93 |  |  | 0 |  | ELOUADRHIRI L | 1 | 1 | U | LATIFA E | 12-007 | 12-027 |  |  | 1017.93 | 0 | 0 | 100 | 11-026 |  | 08-016 | 09-012 |  | 24231007 | 13-002F | PE | 13-015 | PR | OB |  |  |
| 24231045 |  | GTP procurement (2 boards) | 78d | 2013-11-01 | 2014-03-05 | 9-140M FS+23d |  |  |  |  | 328d | 0d | 8/5 M-F w/JLAB Holidays ReBaseline | PROCUREMENT<$50K 60 | 14,446.6 |  |  | 0 | IN | ELOUADRHIRI L | 1 | 1 | U | LATIFA E | 12-007 | 12-027 | 12-054 |  | 14446.6 | 0 | 0 | 100 |  |  |  |  |  | 24231045 | 13-002F | PE | 13-015 | PR |  | 14-001 |  |
| 24231005 |  | CTP procurement Prep | 20d | 2014-10-01 | 2014-10-28 | 9-155M |  |  |  |  | 41d | 0d | 8/5 M-F w/JLAB Holidays ReBaseline | ELEC ENG [80 h] | 6,010.4 |  |  | 0 |  | ELOUADRHIRI L | 1 | 1 | H | LATIFA E | 12-007 | 12-027 |  |  |  |  |  |  | 11-026 |  | 08-016 | 09-012 |  | 24231005 | 13-002F |  | 13-015 | PR |  | 14-001 | PE |
| 24231007 |  | CTP procurement (22 boards) | 119d | 2014-10-29 | 2015-04-28 | 24231005 |  |  |  |  | 41d | 0d | 8/5 M-F w/JLAB Holidays ReBaseline | PROCUREMENT<$50K 60; PROCUREMENT>$50K 69 | 158,912.6 |  |  | 0 |  | ELOUADRHIRI L | 1 | 1 | U | LATIFA E | 12-007 | 12-027 |  |  | 158912.6 | 0 | 0 | 100 | 11-026 |  | 08-016 | 09-012 |  | 24231007 | 13-002F | PE | 13-015 | PR |  | 14-001 |  |

| ID | WBS | Activity | Type | Duration | Start | Finish | Predecessors | Complete | Planned start | Planned finish | Total float | Free float | Calendar | Resources | Cost | Actual cost | LOE % Pre Calc | LOE % | LOE Divider | LOE Multiplier | Calculated Remaining Total Cost | MONTHLY EV COST | RESP - Responsibility | STRT%COMP for CM EVM | FNSH%COMP for CM EVM | EVMS Reporting Codes | CAM RESPONSIBLE | CR 11-026 | CR 12-007 | Claimed Material Divider | ReBaseline Actuals Adjustment | Original Activity ID Rebaseline | Remaining Material Cost Based on % Compl | Claimed Material Cost Based on % Complet | Initial Claimed Material Calc | PHAS - Project Phase | CR 12-027 | CR 12-054 | CR 13-002 | BOE Procurement | CR 13-015 | Post Rebaseline | CR 14-001 | CR 08-016 | Activities with Steps | CR 09-012 | CR 09-030 Repair | BOE Labor |
| --- | --- | --- | --- | --- | --- | --- | --- | --- | --- | --- | --- | --- | --- | --- | --- | --- | --- | --- | --- | --- | --- | --- | --- | --- | --- | --- | --- | --- | --- | --- | --- | --- | --- | --- | --- | --- | --- | --- | --- | --- | --- | --- | --- | --- | --- | --- | --- | --- |
|  | 2 | **1.4.2.3.2 DAQ** |  |  | 2012-01-03 | 2015-08-12 |  |  |  |  |  |  |  |  |  |  |  |  |  |  |  |  |  |  |  |  |  |  |  |  |  |  |  |  |  |  |  |  |  |  |  |  |  |  |  |  |  |  |
| 14232010 |  | CLAS12 DAQ/online software updates FY12 |  | 189d | 2012-01-03 A | 2012-09-28 A | 9-120M FS+58d | 100% |  |  |  |  |  | PD UNIV STUDNT [1066.94 h]; VISTNG USERS [533.47 h]; SCIENTIST [533.47 h] | 59,364.55 | 59,364.55 | 10.05291005 | 89.94708994 | 100 | 100 | 0 | 59364.5416 | ELOUADRHIRI L | 1 | 1 | E | LATIFA E | 11-026 | 12-007 |  |  |  |  |  |  |  |  |  |  |  |  |  |  |  |  |  |  |  |
| 14232030 |  | Re-Baseline Actuals Adjustment |  | 1d | 2013-08-30 A | 2013-08-30 A |  | 100% | 2013-09-03 | 2013-09-03 |  |  |  | PROCUREMENT>$50K 69 NO ESCALATION | -43,873.11 |  |  |  |  |  |  |  |  |  |  |  |  |  |  | 100 | ADJ |  |  |  |  |  |  |  |  |  |  |  |  |  |  |  |  |  |
| 24232022 |  | Procure GE VME controllers (53) |  | 126d | 2014-10-01 | 2015-04-09 | 9-155M |  |  |  | 92d | 0d | 8/5 M-F w/JLAB Holidays ReBaseline | PROCUREMENT>$50K 69; PROCUREMENT<$50K 60 | 218,762.8 |  |  |  |  |  |  | 0 | ELOUADRHIRI L | 1 | 1 | U | LATIFA E |  | 12-007 | 100 |  | 24232022 | 218762.8 | 0 | 0 | IN | 12-027 | 12-054 | 13-002F | EV | 13-015 | PR | 14-001 |  |  |  |  |  |
| 24232025 |  | Install GE VME controllers (22) |  | 86d | 2015-04-10 | 2015-08-12 | 24232022 |  |  |  | 92d | 185d | 8/5 M-F w/JLAB Holidays ReBaseline | SCIENTIST [320 h] | 24,057.6 |  |  |  |  |  |  | 0 | ELOUADRHIRI L | 1 | 1 | S | LATIFA E | 11-026 | 12-007 |  |  | 24232025 |  |  |  | IN | 12-027 | 12-054 | 13-002F |  | 13-015 | PR | 14-001 | 08-016 | ST | 09-012 | 09-030 | PE |
|  | 3 | **1.4.2.3.3 ONLINE COMPUTING** |  |  | 2011-11-01 | 2015-07-21 |  |  |  |  |  |  |  |  |  |  |  |  |  |  |  |  |  |  |  |  |  |  |  |  |  |  |  |  |  |  |  |  |  |  |  |  |  |  |  |  |  |  |
| 14233005 |  | ONLINE COMP-P-#1 Contsruction Setup Historical Contributed Labor |  | 10d | 2011-11-01 A | 2011-11-14 A | 9-120M | 100% |  |  |  |  |  | CONTRB UNIV LBR [13.71 h] |  |  |  |  |  |  |  | 0 | ELOUADRHIRI L | 1 | 1 | Z | LATIFA E | 11-026 | 12-007 |  |  |  |  |  |  |  |  |  |  |  |  |  |  |  |  | 09-012 |  |  |
| 14233007 |  | CLAS12 Online and Monitoring software updates |  | 189d | 2012-01-03 A | 2012-09-28 A | 9-120M FS+61d | 100% |  |  |  |  |  | SCIENTIST [1120 h] | 79,083.2 | 79,083.2 | 10.05291005 | 89.94708994 | 100 | 100 | 0 | 79083.2 | ELOUADRHIRI L | 1 | 1 | E | LATIFA E |  | 12-007 |  |  |  |  |  |  | IN |  |  |  |  |  |  |  |  |  |  |  |  |
| 14233075 |  | Re-Baseline Actuals Adjustment |  | 1d | 2013-08-30 A | 2013-08-30 A |  | 100% | 2013-09-03 | 2013-09-03 |  |  |  | PROCUREMENT>$50K 69 NO ESCALATION | -75,132.85 |  |  |  |  |  |  |  |  |  |  |  |  |  |  | 100 | ADJ |  |  |  |  |  |  |  |  |  |  |  |  |  |  |  |  |  |
| 24233010 |  | Ethernet wiring inside Hall B (10Gbit) |  | 78d | 2015-01-05 | 2015-04-23 | 9-155M FS+60d |  |  |  | 168d | 60d | 8/5 M-F w/JLAB Holidays ReBaseline | PROCUREMENT<$50K 60 | 43,339.8 |  |  |  |  |  |  | 0 | ELOUADRHIRI L | 1 | 1 | D | LATIFA E | 11-026 | 12-007 | 100 |  | 24233010 | 43339.8 | 0 | 0 |  |  | 12-054 | 13-002F | EV | 13-015 | PR | 14-001 |  |  | 09-012 |  |  |
| 24233015 |  | Trigger system fibers wiring |  | 78d | 2015-01-05 | 2015-04-23 | 9-155M FS+60d |  |  |  | 168d | 60d | 8/5 M-F w/JLAB Holidays ReBaseline | PROCUREMENT<$50K 60 | 54,690.7 |  |  |  |  |  |  | 0 | ELOUADRHIRI L | 1 | 1 | D | LATIFA E | 11-026 | 12-007 | 100 |  | 24233015 | 54690.7 | 0 | 0 | IN |  | 12-054 | 13-002F | EV | 13-015 | PR | 14-001 |  |  |  |  |  |
| 24233020 |  | Procure CISCO 2960S switches (24 Cu ports) (15) |  | 78d | 2015-01-05 | 2015-04-23 | 9-155M FS+60d |  |  |  | 127d | 0d | 8/5 M-F w/JLAB Holidays ReBaseline | PROCUREMENT<$50K 60; PROCUREMENT>$50K 69 | 68,105.4 |  |  |  |  |  |  | 0 | ELOUADRHIRI L | 1 | 1 | U | LATIFA E |  | 12-007 | 100 |  | 24233020 | 68105.4 | 0 | 0 | IN |  | 12-054 | 13-002F | PE | 13-015 | PR | 14-001 |  |  |  |  |  |
| 24233030 |  | Procure 4-port 10GBit Blades for BigIron |  | 78d | 2015-01-05 | 2015-04-23 | 9-155M FS+60d |  |  |  | 148d | 0d | 8/5 M-F w/JLAB Holidays ReBaseline | PROCUREMENT<$50K 60; PROCUREMENT>$50K 69 | 51,595 |  |  |  |  |  |  | 0 | ELOUADRHIRI L | 1 | 1 | U | LATIFA E |  | 12-007 | 100 |  | 24233030 | 51595 | 0 | 0 | IN |  | 12-054 | 13-002F | PE | 13-015 | PR | 14-001 |  |  |  |  |  |
| 24233040 |  | Procure Ethernet fibers/Cu wires |  | 78d | 2015-01-05 | 2015-04-23 | 9-155M FS+60d |  |  |  | 127d | 0d | 8/5 M-F w/JLAB Holidays ReBaseline | PROCUREMENT<$50K 60 | 21,669.9 |  |  |  |  |  |  | 0 | ELOUADRHIRI L | 1 | 1 | D | LATIFA E |  | 12-007 | 100 |  | 24233040 | 21669.9 | 0 | 0 | IN |  | 12-054 | 13-002F | CP | 13-015 | PR | 14-001 |  |  |  |  |  |
| 24233050 |  | Procure Terminal servers (Etherlite32) (10) |  | 78d | 2015-01-05 | 2015-04-23 | 9-155M FS+60d |  |  |  | 127d | 0d | 8/5 M-F w/JLAB Holidays ReBaseline | PROCUREMENT<$50K 60 | 15,478.5 |  |  |  |  |  |  | 0 | ELOUADRHIRI L | 1 | 1 | U | LATIFA E |  | 12-007 | 100 |  | 24233050 | 15478.5 | 0 | 0 | IN |  | 12-054 | 13-002F | CP | 13-015 | PR | 14-001 |  |  |  |  |  |
| 24233060 |  | Procure daq/online computers |  | 98d | 2015-01-05 | 2015-05-21 | 9-155M FS+60d |  |  |  | 108d | 0d | 8/5 M-F w/JLAB Holidays ReBaseline | PROCUREMENT>$50K 69; PROCUREMENT<$50K 60 | 85,647.7 |  |  |  |  |  |  | 0 | ELOUADRHIRI L | 1 | 1 | D | LATIFA E |  | 12-007 | 100 |  | 24233060 | 85647.7 | 0 | 0 | IN |  | 12-054 | 13-002F | CP | 13-015 | PR | 14-001 |  |  |  |  |  |
| 24233025 |  | Install CISCO 2960S switches (24 Cu ports) (15) |  | 41d | 2015-04-24 | 2015-06-23 | 24233020 |  |  |  | 127d | 19d | 8/5 M-F w/JLAB Holidays ReBaseline | SCIENTIST [160 h] | 12,028.8 |  |  |  |  |  |  | 0 | ELOUADRHIRI L | 1 | 1 | S | LATIFA E |  | 12-007 |  |  | 24233025 |  |  |  | IN |  | 12-054 | 13-002F |  | 13-015 | PR | 14-001 |  | ST |  |  | PE |
| 24233035 |  | Install 4-port 10GBit Blades for BigIron |  | 20d | 2015-04-24 | 2015-05-21 | 24233030 |  |  |  | 148d | 40d | 8/5 M-F w/JLAB Holidays ReBaseline | SCIENTIST [40 h] | 3,007.2 |  |  |  |  |  |  | 0 | ELOUADRHIRI L | 1 | 1 | H | LATIFA E |  | 12-007 |  |  | 24233035 |  |  |  | IN |  | 12-054 | 13-002F |  | 13-015 | PR | 14-001 |  |  |  |  | PE |
| 24233045 |  | Install Ethernet fibers/Cu wires |  | 41d | 2015-04-24 | 2015-06-23 | 24233040 |  |  |  | 127d | 19d | 8/5 M-F w/JLAB Holidays ReBaseline | SCIENTIST [80 h] | 6,014.4 |  |  |  |  |  |  | 0 | ELOUADRHIRI L | 1 | 1 | H | LATIFA E |  | 12-007 |  |  | 24233045 |  |  |  | IN |  | 12-054 | 13-002F |  | 13-015 | PR | 14-001 |  |  |  |  | PE |
| 24233055 |  | Install Terminal servers (Etherlite32) (10) |  | 41d | 2015-04-24 | 2015-06-23 | 24233050 |  |  |  | 127d | 19d | 8/5 M-F w/JLAB Holidays ReBaseline | SCIENTIST [40 h] | 3,007.2 |  |  |  |  |  |  | 0 | ELOUADRHIRI L | 1 | 1 | H | LATIFA E |  | 12-007 |  |  | 24233055 |  |  |  | IN |  | 12-054 | 13-002F |  | 13-015 | PR | 14-001 |  |  |  |  | PE |
| 24233065 |  | Install daq/online computers |  | 40d | 2015-05-22 | 2015-07-21 | 24233060 |  |  |  | 108d | 0d | 8/5 M-F w/JLAB Holidays ReBaseline | SCIENTIST [280 h] | 21,050.4 |  |  |  |  |  |  | 0 | ELOUADRHIRI L | 1 | 1 | S | LATIFA E |  | 12-007 |  |  | 24233065 |  |  |  | IN |  | 12-054 | 13-002F |  | 13-015 | PR | 14-001 |  | ST |  |  | PE |
| 24233070M |  | Online computing infrastructure complete | milestone | 0d | 2015-07-21 | 2015-07-21 | 24233010, 24233055, 24233045, 24233035, 24233065, 24233015, 24233025 |  |  |  | 108d | 201d | 8/5 M-F w/JLAB Holidays ReBaseline |  |  |  |  |  |  |  |  | 0 | ELOUADRHIRI L | 1 | 1 | M | LATIFA E |  | 12-007 |  |  | 24233070M |  |  |  | IN |  | 12-054 | 13-002F |  | 13-015 | PR |  |  |  |  |  |  |
|  | 4 | **1.4.2.3.4 OFFLINE COMPUTING** |  |  | 2011-12-01 | 2013-08-30 |  |  |  |  |  |  |  |  |  |  |  |  |  |  |  |  |  |  |  |  |  |  |  |  |  |  |  |  |  |  |  |  |  |  |  |  |  |  |  |  |  |  |
| 14234020LOE |  | Contributed Labor Effort |  | 702d | 2011-12-01 A | 2013-08-30 A | 9-120M FS+41d | 100% | 2011-12-01 | 2014-09-30 |  |  |  | CONTRB UNIV LBR [6429.67 h] |  |  | 38.17663817 | 61.82336182 | 100 | 100 |  | 0 | ELOUADRHIRI L | 1 | 1 | E | LATIFA E | 11-026 | 12-007 |  |  |  |  |  |  |  |  |  |  |  |  |  |  |  |  |  |  |  |
| 14234005 |  | OFFLINE COMP- Constrctn Setup (P-#1) Historical |  | 6d | 2011-12-03 A | 2011-12-12 A | 9-120M | 100% | 2011-12-05 | 2011-12-12 |  |  |  | VISTNG USERS [89.14 h]; SCIENTIST [13.71 h]; CONTRB UNIV LBR [287.99 h]; COMP SCIENT [13.71 h] | 3,591.33 | 3,591.33 |  |  |  |  | 0 | 3591.327078 | ELOUADRHIRI L | 1 | 1 | H | LATIFA E | 11-026 | 12-007 |  |  |  |  |  |  |  |  |  |  |  |  |  |  |  |  |  |  |  |
| 14234025 |  | Re-Baseline Actuals Adjustment |  | 1d | 2013-08-30 A | 2013-08-30 A |  | 100% | 2013-09-03 | 2013-09-03 |  |  |  | PROCUREMENT>$50K 69 NO ESCALATION | -3,591.33 |  |  |  |  |  |  |  |  |  |  |  |  |  |  | 100 | ADJ |  |  |  |  |  |  |  |  |  |  |  |  |  |  |  |  |  |

Notes:
- 24232025: Steps: Install in crates and wire up; Register IP names, determine test software to be used; Boot one by one and run test software; send to repair if needed
- 24233025: Steps: Install CISCO switches in racks and wire up; Configure all switches for corresponding subnets
- 24233065: Steps: Install daq/online computers hardware and wire up; Install operating systems and daq/online software; Test entire system

| ID | WBS | Activity | Type | Duration | Start | Finish | Predecessors | Complete | Remaining | Planned start | Planned finish | Total float | Free float | Calendar | Resources | Cost | Actual cost | Calculated Remaining Total Cost | MONTHLY EV COST | RESP - Responsibility | STRT%COMP for CM EVM | FNSH%COMP for CM EVM | EVMS Reporting Codes | CAM RESPONSIBLE | Activities with Steps | CR 11-026 | MARCH!!! | CR 12-001 | CR 08-016 | CR 09-012 | Claimed Material Divider | ReBaseline Actuals Adjustment | Original Activity ID Rebaseline | Remaining Material Cost Based on % Compl | Claimed Material Cost Based on % Complet | Initial Claimed Material Calc | CR 13-002 | BOE Procurement | CR 13-015 | Post Rebaseline | Obligated Prior to Rebaseline | CR 14-001 | BOE Labor | PHAS - Project Phase | CR 08-052 | CR 11-035 | CR 12-007 | CR 12-014 | CR 12-047 | Advance Purchase Plan > 500K | CR 08-045 | 12 GEV MAJOR PROCUREMENT CATAGORY | Phil Dev | CR 12-016 | CR 12-054 | CR 12-027 | CR 12-053 | Pre Rebaseline Remaining Budget | BOE Expenses | Previously In Progress |
| --- | --- | --- | --- | --- | --- | --- | --- | --- | --- | --- | --- | --- | --- | --- | --- | --- | --- | --- | --- | --- | --- | --- | --- | --- | --- | --- | --- | --- | --- | --- | --- | --- | --- | --- | --- | --- | --- | --- | --- | --- | --- | --- | --- | --- | --- | --- | --- | --- | --- | --- | --- | --- | --- | --- | --- | --- | --- | --- | --- | --- |
|  | 5 | **1.4.2.3.5 SLOW CONTROLS** |  |  | 2011-04-01 | 2015-03-17 |  |  |  |  |  |  |  |  |  |  |  |  |  |  |  |  |  |  |  |  |  |  |  |  |  |  |  |  |  |  |  |  |  |  |  |  |  |  |  |  |  |  |  |  |  |  |  |  |  |  |  |  |  |  |
| 14235005 |  | SLOW CNTL- Constrctn Setup (P-#1) |  | 438d | 2011-04-01 A | 2013-08-30 A | 12223045, 9-110M | 100% |  | 2011-04-01 | 2013-01-07 |  |  |  | SCIENTIST [560 h]; VISTNG USERS [1040 h] | 59,379.66 | 59,973.43 | 23120 | 57800 | ELOUADRHIRI L | 1 | 1 | S | LATIFA E | ST | 11-026 | XX |  |  |  |  |  |  |  |  |  |  |  |  |  |  |  |  |  |  |  |  |  |  |  |  |  |  |  |  |  |  |  |  |  |
| 14235010 |  | SLOW CNTL- Constrctn Setup (P-#2) FY11 |  | 3d | 2013-08-30 A | 2013-08-30 A | 14235005 | 100% |  | 2013-10-01 | 2013-10-03 |  |  |  | SCIENTIST [7.84 h]; VISTNG USERS [15.18 h] | 901.97 | 874.06 | 820.8126 | 820.8126 | ELOUADRHIRI L | 1 | 1 | S | LATIFA E | ST | 11-026 | XX | 12-001 |  |  |  |  |  |  |  |  |  |  |  |  |  |  |  |  |  |  |  |  |  |  |  |  |  |  |  |  |  |  |  |  |
| 14235010a |  | SLOW CNTL- Constrctn Setup (P-#2) FY12 |  | 224d | 2013-08-30 A | 2013-08-30 A | 14235010 | 100% |  | 2013-10-04 | 2014-08-29 |  |  |  | SCIENTIST [632.16 h]; VISTNG USERS [1224.82 h] | 72,744.83 | 70,494.34 | 68312.5882 | 68312.5882 | ELOUADRHIRI L | 1 | 1 | S | LATIFA E | ST | 11-026 |  | 12-001 |  |  |  |  |  |  |  |  |  |  |  |  |  |  |  |  |  |  |  |  |  |  |  |  |  |  |  |  |  |  |  |  |
| 14235015 |  | SLOW CNTL- Constrctn Setup (P-#3) |  | 245d | 2013-08-30 A | 2013-08-30 A | 14235010a | 100% |  | 2013-09-03 | 2014-08-27 |  |  |  | VISTNG USERS [1153.96 h]; SCIENTIST [558.37 h]; PROCUREMENT<$50K 60 | 65,572.17 | 63,704.26 | 132370.01 | 63704.259671 | ELOUADRHIRI L | 1 | 1 | S | LATIFA E | ST | 11-026 |  | 12-001 | 08-016 | 09-012 |  |  |  |  |  |  |  |  |  |  |  |  |  |  |  |  |  |  |  |  |  |  |  |  |  |  |  |  |  |  |
| 14235020 |  | Re-Baseline Actuals Adjustment |  | 1d | 2013-08-30 A | 2013-08-30 A |  | 100% |  | 2013-09-03 | 2013-09-03 |  |  |  | PROCUREMENT>$50K 69 NO ESCALATION | -133,300.56 |  |  |  |  |  |  |  |  |  |  |  |  |  |  | 100 | ADJ |  |  |  |  |  |  |  |  |  |  |  |  |  |  |  |  |  |  |  |  |  |  |  |  |  |  |  |  |
| 24235005 |  | SLOW CNTL (EPICS software development) |  | 34d | 2013-10-01 A | 2013-12-20 | 9-140M FS+23d | 50% | 34d | 2013-11-01 | 2013-12-20 | 195d | 0d | 8/5 M-F w/JLAB Holidays ReBaseline | PROCUREMENT<$50K 60 | 9,390.29 |  |  | 4695.145 | ELOUADRHIRI L | 1 | 1 | D | LATIFA E |  | 11-026 |  | 12-001 |  |  | 100 |  | 24235005 | 4695.145 | 4695.145 | 469514.5 | 13-002F | OB | 13-015 | PR | OB-2 | 14-001 |  |  |  |  |  |  |  |  |  |  |  |  |  |  |  |  |  |  |
| 24235010a |  | SLOW CNTL (EPICS device drivers development) |  | 189d | 2014-01-02 | 2014-09-29 | 9-140M FS+59d, 24235005 |  |  |  |  | 195d | 0d | 8/5 M-F w/JLAB Holidays ReBaseline | SCIENTIST [880 h] | 66,158.4 |  |  | 0 | ELOUADRHIRI L | 1 | 1 | S | LATIFA E | ST | 11-026 |  | 12-001 |  |  |  |  | 24235010a |  |  |  | 13-002F |  | 13-015 | PR |  | 14-001 | PE |  |  |  |  |  |  |  |  |  |  |  |  |  |  |  |  |  |
| 24235015 |  | SLOW CNTL (EPICS software development) |  | 110d | 2014-09-30 | 2015-03-17 | 24235010a |  |  |  |  | 195d | 288d | 8/5 M-F w/JLAB Holidays ReBaseline | SCIENTIST [880 h]; VISTNG USERS [3520 h] | 138,635.2 |  |  | 0 | ELOUADRHIRI L | 1 | 1 | S | LATIFA E | ST | 11-026 |  | 12-001 | 08-016 | 09-012 |  |  | 24235015 |  |  |  | 13-002F |  | 13-015 | PR |  | 14-001 | PE | IN |  |  |  |  |  |  |  |  |  |  |  |  |  |  |  |  |
|  | 4 | **1.4.2.4 ELECTRONICS** |  |  | 2010-09-13 | 2015-10-01 |  |  |  |  |  |  |  |  |  |  |  |  |  |  |  |  |  |  |  |  |  |  |  |  |  |  |  |  |  |  |  |  |  |  |  |  |  |  |  |  |  |  |  |  |  |  |  |  |  |  |  |  |  |  |
|  | 1 | **1.4.2.4.1 ADC** |  |  | 2011-11-01 | 2013-08-30 |  |  |  |  |  |  |  |  |  |  |  |  |  |  |  |  |  |  |  |  |  |  |  |  |  |  |  |  |  |  |  |  |  |  |  |  |  |  |  |  |  |  |  |  |  |  |  |  |  |  |  |  |  |  |
| 14241005 |  | ADC Prcrmnt prep |  | 15d | 2011-11-01 A | 2011-11-21 A | 9-120M, 12224005 | 100% |  |  |  |  |  |  | SCIENTIST [40 h]; ELEC TECH [160 h] | 9,885.2 | 9,885.2 | 0 | 9885.2 | ELOUADRHIRI L | 1 | 1 | H | LATIFA E |  |  |  |  |  |  |  |  |  |  |  |  |  |  |  |  |  |  |  |  | 08-052 | 11 -035 | 12-007 | 12-014 | 12-047F |  |  |  |  |  |  |  |  |  |  |  |
| 14241010 |  | FADC-250 (275) procurement |  | 220d | 2012-01-03 A | 2012-11-12 A | 14241005 FS+21d, 9-120M FS+59d | 100% |  |  |  |  |  |  | PROCUREMENT<$50K 60 NO ESCALATION; PROCUREMENT>$50K 69 NO ESCALATION | 1,136,336.85 |  | 0 | 1136336.85 | ELOUADRHIRI L | 1 | 1 | D | LATIFA E |  |  |  |  |  |  | 100 |  |  | 0 | 1136336.85 | 113633685 |  |  |  |  |  |  |  | IN |  | 11 -035 | 12-007 | 12-014 | 12-047F | APP | 08-045 | 4241 | MP |  |  |  |  |  |  |  |
| 14241015 |  | UMASS - FADC-250 testing (275) |  | 135d | 2012-09-10 A | 2013-02-25 A | 14241010 FS-60d, 12224005 | 100% |  | 2012-09-10 | 2013-03-29 |  |  |  | PROCUREMENT<$50K 60 | 3,523.32 |  | 0 | 3523.32 | ELOUADRHIRI L | 1 | 1 | U | LATIFA E |  |  |  |  |  |  | 100 |  |  | 0 | 3523.32 | 352332 |  |  |  |  |  |  |  |  | 08-052 | 11 -035 | 12-007 | 12-014 | 12-047 |  |  |  |  |  |  |  |  |  |  |  |
| 14241020 |  | Re-Baseline Actuals Adjustment |  | 1d | 2013-08-30 A | 2013-08-30 A |  | 100% |  | 2013-09-03 | 2013-09-03 |  |  |  | PROCUREMENT>$50K 69 NO ESCALATION | 42,472.21 |  |  | 42472.21 |  |  |  |  |  |  |  |  |  |  |  | 100 | ADJ |  | 0 | 42472.21 | 4247221 |  |  |  |  |  |  |  |  |  |  |  |  |  |  |  |  |  |  |  |  |  |  |  |  |
|  | 2 | **1.4.2.4.2 TDC AND DISCRIMINATORS** |  |  | 2012-01-03 | 2015-10-01 |  |  |  |  |  |  |  |  |  |  |  |  |  |  |  |  |  |  |  |  |  |  |  |  |  |  |  |  |  |  |  |  |  |  |  |  |  |  |  |  |  |  |  |  |  |  |  |  |  |  |  |  |  |  |
| 14242033 |  | JLab Discriminator First Article and Non-Recurring Engineering |  | 29d | 2012-01-03 A | 2012-02-13 A | 9-120M FS+59d | 100% |  |  |  |  |  |  | PROCUREMENT<$50K 60 NO ESCALATION; PROCUREMENT>$50K 69 NO ESCALATION | 26,137.5 |  | 0 | 26137.5 | ELOUADRHIRI L | 1 | 1 | D | LATIFA E |  |  |  |  |  |  | 100 |  |  | 0 | 26137.5 | 2613750 |  |  |  |  |  |  |  | IN |  |  |  |  |  | APP |  | 4242 |  | 12-016 | 12-054F |  |  |  |  |  |
| 14242035 |  | JLab Discriminator (275) procurement |  | 270d | 2012-01-03 A | 2012-12-17 A | 14242033 FS-104d | 100% |  | 2012-01-03 | 2013-02-01 |  |  |  | PROCUREMENT<$50K 60 NO ESCALATION; PROCUREMENT>$50K 69 NO ESCALATION | 390,403 |  | 0 | 390403 | ELOUADRHIRI L | 1 | 1 | D | LATIFA E |  |  |  |  |  |  | 100 |  |  | 0 | 390403 | 39040300 |  |  |  |  |  |  |  | IN |  |  | 12-007 |  |  | APP |  | 4242 |  | 12-016 | 12-054F |  |  |  |  |  |
| 14242020 |  | JLab TDC Fanout procurement prep |  | 11d | 2012-07-02 A | 2012-07-16 A | 9-120M FS+120d | 100% |  |  |  |  |  |  | SCIENTIST [40 h] | 2,824.4 | 2,824.4 | 0 | 2914.4 | ELOUADRHIRI L | 1 | 1 | H | LATIFA E |  |  |  |  |  |  |  |  |  |  |  |  |  |  |  |  |  |  |  | IN |  |  | 12-007 |  |  | APP |  | 4242 |  |  |  | 12-027 |  |  |  |  |
| 14242050 |  | ORTEC 935F discr. (25) procurement |  | 191d | 2012-07-02 A | 2013-01-25 A | 14242045 FS-45d | 100% |  | 2012-07-02 | 2013-04-09 |  |  |  | PROCUREMENT<$50K 60; PROCUREMENT>$50K 69 | 87,814.69 |  | 0 | 87814.69 | ELOUADRHIRI L | 1 | 1 | D | LATIFA E |  |  |  |  |  |  | 100 |  |  | 0 | 87814.69 | 8781469 |  |  |  |  |  |  |  | IN |  |  | 12-007 |  |  | APP |  | 4242 |  |  |  | 12-027 |  |  |  |  |
| 14242025 |  | JLab TDC Fanout (25) procurement |  | 169d | 2012-08-01 A | 2012-12-17 A | 14242020 | 100% |  | 2012-08-01 | 2013-04-09 |  |  |  | PROCUREMENT<$50K 60; PROCUREMENT>$50K 69 | 51,595 |  | 0 | 51595 | ELOUADRHIRI L | 1 | 1 | D | LATIFA E |  |  |  |  |  |  | 100 |  |  | 0 | 51595 | 5159500 |  |  |  |  |  |  |  | IN |  |  | 12-007 |  |  | APP |  | 4242 |  |  |  | 12-027 |  |  |  |  |
| 14242040 |  | JLab Discriminator (275) test/install |  | 179d | 2012-09-03 A | 2013-08-30 A | 14242035 FS-60d | 100% |  | 2012-09-04 | 2013-05-24 |  |  |  | PD UNIV STUDNT [320 h] | 3,511.65 | 3,514.83 | 1056.96 | 3523.2 | ELOUADRHIRI L | 1 | 1 | U | LATIFA E |  |  |  |  |  |  |  |  |  |  |  |  |  |  |  |  |  |  |  | IN |  |  | 12-007 |  |  | APP |  | 4242 |  | 12-016 | 12-054 |  | 12-053 |  |  |  |
| 14242005 |  | CAEN v1190 TDCs (reuse) (31) installation |  | 11d | 2012-10-01 A | 2012-10-15 A | 12224005, 9-120M FS+163d | 100% |  |  |  |  |  |  | SCIENTIST [8 h] | 582.88 | 582.88 | 0 | 564.88 | ELOUADRHIRI L | 1 | 1 | U | LATIFA E |  | 11-026 |  |  |  |  |  |  |  |  |  |  |  |  |  |  |  |  |  |  |  |  | 12-007 |  |  |  |  |  |  |  |  |  |  |  |  |  |
| 14242010 |  | CAEN v1290 TDCs (reuse) (24) installation |  | 11d | 2012-10-01 A | 2012-10-15 A | 9-120M FS+163d | 100% |  |  |  |  |  |  | SCIENTIST [8 h] | 582.88 | 582.88 | 0 | 564.88 | ELOUADRHIRI L | 1 | 1 | U | LATIFA E |  | 11-026 |  |  |  |  |  |  |  |  |  |  |  |  |  |  |  |  |  | IN |  |  | 12-007 |  |  | APP | 08-045 | 4242 |  |  |  |  |  |  |  |  |
| 14242015 |  | CAEN v1290N TDCs (reuse) (7) installation |  | 11d | 2012-10-01 A | 2012-10-15 A | 9-120M FS+163d | 100% |  |  |  |  |  |  | SCIENTIST [8 h] | 582.88 | 582.88 | 0 | 564.88 | ELOUADRHIRI L | 1 | 1 | U | LATIFA E |  |  |  |  |  |  |  |  |  |  |  |  |  |  |  |  |  |  |  | IN |  |  | 12-007 |  |  | APP |  | 4242 |  |  |  |  |  |  |  |  |
| 14242055 |  | ORTEC 935F discr. (25) test/install |  | 59d | 2013-01-02 A | 2013-01-31 A | 14242050 | 100% |  | 2013-01-02 | 2013-03-27 |  |  |  | SCIENTIST [40 h] | 2,914.4 | 2,914.4 | 0 | 2914.4 | ELOUADRHIRI L | 1 | 1 | U | LATIFA E |  |  |  |  |  |  |  |  |  |  |  |  |  |  |  |  |  |  |  | IN |  |  | 12-007 |  |  | APP |  | 4242 |  |  |  | 12-027 |  |  |  |  |
| 14242045 |  | ORTEC 935F discr. procurement prep |  | 7d | 2013-01-08 A | 2013-01-16 A | 9-130M | 100% |  |  |  |  |  |  | SCIENTIST [40 h] | 2,914.4 | 2,914.4 | 0 | 2914.4 | ELOUADRHIRI L | 1 | 1 | U | LATIFA E |  |  | XX |  |  |  |  |  |  |  |  |  |  |  |  |  |  |  |  | IN |  |  | 12-007 |  |  | APP |  | 4242 |  |  |  | 12-027 |  |  |  |  |
| 14242030 |  | JLab TDC Fanout (25) test/install |  | 59d | 2013-08-30 A | 2013-08-30 A | 14242025 | 100% |  | 2013-09-03 | 2013-11-22 |  |  |  | SCIENTIST [40 h] | 2,975.74 | 2,914.4 | 2914.4 | 2914.4 | ELOUADRHIRI L | 1 | 1 | U | LATIFA E |  |  |  |  |  |  |  |  |  |  |  |  |  |  |  |  |  |  |  | IN |  |  | 12-007 |  |  | APP |  | 4242 |  |  |  | 12-027 |  |  |  |  |
| 14242065 |  | Re-Baseline Actuals Adjustment |  | 1d | 2013-08-30 A | 2013-08-30 A |  | 100% |  | 2013-09-03 | 2013-09-03 |  |  |  | PROCUREMENT>$50K 69 NO ESCALATION | -55,558.26 |  |  |  |  |  |  |  |  |  |  |  |  |  |  | 100 | ADJ |  |  |  |  |  |  |  |  |  |  |  |  |  |  |  |  |  |  |  |  |  |  |  |  |  |  |  |  |
| 14242060M |  | TDC and Discriminators Complete | milestone | 0d | 2013-08-30 A | 2013-08-30 A | 14242015, 14242040, 14242055, 14242030, 14242005, 14242010 | 100% |  | 2013-11-22 | 2013-11-22 |  |  |  |  |  |  |  | 0 | ELOUADRHIRI L | 1 | 1 | M | LATIFA E |  |  |  |  |  |  |  |  |  |  |  |  |  |  |  |  |  |  |  | IN |  |  | 12-007 |  |  |  |  |  |  |  |  | 12-027 |  |  |  |  |
| 24242040a |  | JLab Discriminator (12) and Flash FADC (12) test/install (SF) |  | 128d | 2014-03-31 | 2014-09-29 | 9-140M FS+119d |  |  |  |  | 305d | 248d | 8/5 M-F w/JLAB Holidays ReBaseline | PLABOR | 3,714.84 |  |  | 0 | ELOUADRHIRI L | 1 | 1 | S | LATIFA E | ST |  |  |  |  |  |  |  | 24242040a |  |  |  | 13-002F |  | 13-015 | PR |  | 14-001 | PE | IN |  |  | 12-007 |  |  | APP |  | 4242 |  | 12-016 | 12-054 |  | 12-053 | 2113.92 | PE | Review |
| 24242055 |  | ORTEC 935F Discriminators (24) Test/Install (SF) |  | 128d | 2014-03-31 | 2014-09-29 | 9-140M FS+119d |  |  |  |  | 305d | 248d | 8/5 M-F w/JLAB Holidays ReBaseline | PLABOR | 11,144.52 |  |  | 0 | ELOUADRHIRI L | 1 | 1 | S | LATIFA E | ST |  |  |  |  |  |  |  | 24242055 |  |  |  | 13-002F |  | 13-015 | PR |  | 14-001 | PE | IN |  |  | 12-007 |  |  | APP |  | 4242 |  | 12-016 | 12-054 |  | 12-053 | 2113.92 | PE | Review |
| 24242005 |  | CAEN v1190 (30) and v1290 (24) TDC's installation (FC) |  | 119d | 2014-10-01 | 2015-03-31 | 9-155M, 24264278 |  |  |  |  | 57d | 0d | 8/5 M-F w/JLAB Holidays ReBaseline | PLABOR | 26,003.88 |  |  | 0 | ELOUADRHIRI L | 1 | 1 | S | LATIFA E | ST |  |  |  |  |  |  |  | 24242005 |  |  |  | 13-002F |  | 13-015 | PR |  | 14-001 |  | IN |  |  | 12-007 |  |  |  |  |  |  |  |  | 12-027 |  |  | PE |  |
| 24242010 |  | CAEN v1290 TDC's (1) procurement |  | 161d | 2014-10-01 | 2015-05-29 | 9-155M |  |  |  |  | 143d | 86d | 8/5 M-F w/JLAB Holidays ReBaseline | PROCUREMENT<$50K 60 | 10,319 |  |  | 0 | ELOUADRHIRI L | 1 | 1 | U | LATIFA E |  |  |  |  |  |  | 100 |  | 24242010 | 10319 | 0 | 0 | 13-002F | CP | 13-015 | PR |  | 14-001 |  | IN |  |  | 12-007 |  |  |  |  |  |  |  |  | 12-027 |  |  |  |  |
| 24242030 |  | JLab TDC Fanout (18) test/install (FC) |  | 119d | 2014-10-01 | 2015-03-31 | 9-155M |  |  |  |  | 57d | 0d | 8/5 M-F w/JLAB Holidays ReBaseline | SCIENTIST; PLABOR | 1,857.42 |  |  | 0 | ELOUADRHIRI L | 1 | 1 | S | LATIFA E | ST |  |  |  |  |  |  |  | 24242030 |  |  |  | 13-002F |  | 13-015 | PR |  | 14-001 | PE | IN |  |  | 12-007 |  |  | APP |  | 4242 |  |  |  | 12-027 |  |  | PE |  |
| 24242040 |  | JLab Discriminator (240) and Flash FADC (240) test/install (FC) |  | 77d | 2014-10-01 | 2015-01-30 | 9-155M |  |  |  |  | 227d | 170d | 8/5 M-F w/JLAB Holidays ReBaseline | PLABOR | 31,761.88 |  |  | 0 | ELOUADRHIRI L | 1 | 1 | S | LATIFA E | ST |  |  |  |  |  |  |  | 24242040 |  |  |  | 13-002F |  | 13-015 | PR |  | 14-001 | PE | IN |  |  | 12-007 |  |  | APP |  | 4242 |  | 12-016 | 12-054 |  | 12-053 | 2113.92 | PE | Review |
| 24242057 |  | Radial Connectors and Sockets for HV Distribution Boxes |  | 77d | 2014-10-01 | 2015-01-30 | 9-155M |  |  |  |  | 167d | 126d | 8/5 M-F w/JLAB Holidays ReBaseline | PROCUREMENT<$50K 60 | 16,758.06 |  |  | 0 | ELOUADRHIRI L | 1 | 1 | D | LATIFA E |  |  |  |  |  |  | 100 |  | 24242057 | 16758.06 | 0 | 0 | 13-002F | OB | 13-015 | PR |  | 14-001 |  | IN |  |  | 12-007 |  |  |  |  |  |  |  | 12-054 | 12-027 |  |  |  |  |
| 24242005a |  | CAEN v1190 (1) and v1290N (7) TDC's installation (SF) |  | 128d | 2015-04-01 | 2015-10-01 | 24242005, 24264230 |  |  |  |  | 57d | 0d | 8/5 M-F w/JLAB Holidays ReBaseline | PLABOR | 5,572.26 |  |  | 0 | ELOUADRHIRI L | 1 | 1 | S | LATIFA E | ST |  |  |  |  |  |  |  | 24242005a |  |  |  | 13-002F |  | 13-015 | PR |  | 14-001 |  | IN |  |  | 12-007 |  |  |  |  |  |  |  |  | 12-027 |  |  | PE |  |
| 24242030a |  | JLab TDC Fanout (2) test/install (SF) |  | 128d | 2015-04-01 | 2015-10-01 | 24242030 |  |  |  |  | 57d | 0d | 8/5 M-F w/JLAB Holidays ReBaseline | SCIENTIST; PLABOR | 1,857.42 |  |  | 0 | ELOUADRHIRI L | 1 | 1 | S | LATIFA E | ST |  |  |  |  |  |  |  | 24242030a |  |  |  | 13-002F |  | 13-015 | PR |  | 14-001 | PE | IN |  |  | 12-007 |  |  | APP |  | 4242 |  |  |  | 12-027 |  |  | PE |  |
| 24242060M |  | TDC and Discriminators Complete | milestone | 0d | 2015-10-01 | 2015-10-01 | 24242040, 24242055, 24242030a, 24242010, 24242005a, 24242040a |  |  |  |  | 57d | 150d | 8/5 M-F w/JLAB Holidays ReBaseline |  |  |  |  | 0 | ELOUADRHIRI L | 1 | 1 | M | LATIFA E |  |  |  |  |  |  |  |  | 24242060M |  |  |  | 13-002F |  | 13-015 | PR |  |  |  | IN |  |  | 12-007 |  |  |  |  |  |  |  |  | 12-027 |  |  |  |  |

Notes:
- 14235005: Steps: Upgrade to New version of APEX (done); Reprogram the new devices (done); Add new devices (done)
- 14235010: Steps: Upgrade to New version of APEX (done); Reprogram the new devices (done); Add new devices (done)
- 14235010a: Steps: Upgrade to New version of APEX (done); Reprogram the new devices (done); Add new devices (done)
- 14235015: Steps: Upgrade to New version of APEX (done); Reprogram the new devices (done); Add new devices (done)
- 24235010a: Steps: Develop/install epics drivers for HV/LV systems; Develop/install epics drivers for motor systems; Develop/install epics drivers for magnets; Develop/install epics drivers for other systems
- 24235015: Steps: Develop/install epics iocs; Develop/install epics GUIs; Develop/install epics components (alarm, archiver etc); Develop/install epics monitoring tree including communication with DAQ
- 24242040a: Steps: Install DSC2 and FADC boards on Space Frame; Cable all DSC2 and FADC on Space Frame; Test all DSC2 and FADC running calibration procedures and obtain calibration constants
- 24242055: Steps: Install ORTEC 935 boards on Space Frame; Cable all ORTEC 935 on Space Frame; Test all ORTEC 935 running calibration procedures and obtain calibration constants
- 24242005: Steps: Install v1190/v1290 TDC boards on Forward Carriage; Cable all TDCs on Forward Carriage; Test all TDCs running calibration procedures and obtain calibration constants
- 24242030: Steps: Install TDC FOUT boards on Forward Carriage; Cable all FOUTs on Forward Carriage; Test all FOUTs running DAQ
- 24242040: Steps: Install DSC2 and FADC boards on Forward Carriage; Cable all DSC2 and FADCs on Forward Carriage; Test all DSC2 and FADC running calibration procedures and obtain calibration constants
- 24242005a: Steps: Install v1190/v1290 TDC boards on Space Frame; Cable all TDCs on Space Frame; Test all TDCs running calibration procedures and obtain calibration constants
- 24242030a: Steps: Install TDC FOUT boards on Space Frame; Cable all FOUTs on Space Frame; Test all FOUTs running DAQ

| ID | WBS | Activity | Type | Duration | Start | Finish | Predecessors | Complete | Remaining | Planned start | Planned finish | Total float | Free float | Calendar | Resources | Cost | Actual cost | Calculated Remaining Total Cost | MONTHLY EV COST | RESP - Responsibility | STRT%COMP for CM EVM | FNSH%COMP for CM EVM | EVMS Reporting Codes | CAM RESPONSIBLE | CR 11-026 | MARCH!!! | Claimed Material Divider | ReBaseline Actuals Adjustment | Original Activity ID Rebaseline | Remaining Material Cost Based on % Compl | Claimed Material Cost Based on % Complet | Initial Claimed Material Calc | PHAS - Project Phase | CR 12-027 | CR 12-054 | CR 13-002 | BOE Procurement | CR 13-015 | Post Rebaseline | CR 14-001 | Phil Dev | CR 11-002 | CR 11-029 | Activities with Steps | CR 12-007 | BOE Expenses | BOE Labor | CR 10-077 | CR 10-053 | Obligated Prior to Rebaseline |
| --- | --- | --- | --- | --- | --- | --- | --- | --- | --- | --- | --- | --- | --- | --- | --- | --- | --- | --- | --- | --- | --- | --- | --- | --- | --- | --- | --- | --- | --- | --- | --- | --- | --- | --- | --- | --- | --- | --- | --- | --- | --- | --- | --- | --- | --- | --- | --- | --- | --- | --- |
|  | 3 | **1.4.2.4.3 SCALERS** |  |  | 2012-01-09 | 2015-07-07 |  |  |  |  |  |  |  |  |  |  |  |  |  |  |  |  |  |  |  |  |  |  |  |  |  |  |  |  |  |  |  |  |  |  |  |  |  |  |  |  |  |  |  |  |
| 14243005 |  | SCALERS- Prcrmnt Prep |  | 235d | 2012-01-09 A | 2013-04-15 A | 12224005, 9-120M FS+60d | 100% |  | 2012-01-09 | 2012-12-11 |  |  |  | SCIENTIST [40 h]; ELEC TECH [80 h] | 6,397.95 | 6,438.87 | 0 | 6354.8 | ELOUADRHIRI L | 1 | 1 | H | LATIFA E | 11-026 | XX |  |  |  |  |  |  |  |  |  |  |  |  |  |  |  |  |  |  |  |  |  |  |  |  |
| 14243015 |  | Re-Baseline Actuals Adjustment |  | 1d | 2013-08-30 A | 2013-08-30 A |  | 100% |  | 2013-09-03 | 2013-09-03 |  |  |  | PROCUREMENT>$50K 69 NO ESCALATION | -6,354.8 |  |  |  |  |  |  |  |  |  |  | 100 | ADJ |  |  |  |  |  |  |  |  |  |  |  |  |  |  |  |  |  |  |  |  |  |  |
| 24243010 |  | SCALERS - Procurement/Install (SF) |  | 128d | 2015-01-05 | 2015-07-07 | 9-155M FS+60d |  |  |  |  | 118d | 211d | 8/5 M-F w/JLAB Holidays ReBaseline | PROCUREMENT<$50K 60; PROCUREMENT>$50K 69 | 68,105.4 |  |  | 0 | ELOUADRHIRI L | 1 | 1 | U | LATIFA E | 11-026 |  | 100 |  | 24243010 | 68105.4 | 0 | 0 | IN | 12-027 | 12-054 | 13-002F | CP | 13-015 | PR | 14-001 |  |  |  |  |  |  |  |  |  |  |
|  | 4 | **1.4.2.4.4 HIGH VOLTAGE** |  |  | 2011-11-01 | 2015-07-02 |  |  |  |  |  |  |  |  |  |  |  |  |  |  |  |  |  |  |  |  |  |  |  |  |  |  |  |  |  |  |  |  |  |  |  |  |  |  |  |  |  |  |  |  |
| 14244020 |  | Vend Fab - H.V Channels +3.5 KV 3 MA Floating (QTY13) |  | 217d | 2011-11-01 A | 2012-09-17 A | 14244015 FS-150d | 100% |  |  |  |  |  |  | PROCUREMENT<$50K 60; PROCUREMENT>$50K 69 | 88,992.05 |  | 0 | 88992.05 | ELOUADRHIRI L | 1 | 1 | D | LATIFA E | 11-026 |  | 100 |  |  | 0 | 88992.05 | 8899205 |  |  |  |  |  |  |  |  | MP | 11-002 | 11-029 |  |  |  |  |  |  |  |
| 14244025 |  | Vend Fab - H.V Channels -3.5 KV 3 MA Floating (QTY87) |  | 217d | 2011-11-01 A | 2012-09-17 A | 14244020 FS-130d | 100% |  |  |  |  |  |  | PROCUREMENT>$50K 69 | 562,472.78 |  | 0 | 562472.78 | ELOUADRHIRI L | 1 | 1 | D | LATIFA E | 11-026 |  | 100 |  |  | 0 | 562472.78 | 56247278 |  |  |  |  |  |  |  |  | MP | 11-002 | 11-029 |  |  |  |  |  |  |  |
| 14244005 |  | Hi Voltage Prcrmnt Prep |  | 11d | 2011-12-05 A | 2011-12-19 A | 12224005, 9-120M FS+60d | 100% |  |  |  |  |  |  | SCIENTIST [40 h]; ELEC TECH [80 h] | 6,354.8 | 6,354.8 | 0 | 6354.8 | ELOUADRHIRI L | 1 | 1 | H | LATIFA E | 11-026 |  |  |  |  |  |  |  |  |  |  |  |  |  |  |  |  |  | 11-029 |  |  |  |  |  |  |  |
| 14244010 |  | Vend Fab - Universal Multichannel Power Supply System 750W (QTY 5) |  | 195d | 2011-12-05 A | 2012-09-17 A | 14244005 FS-20d | 100% |  |  |  |  |  |  | PROCUREMENT<$50K 60 | 43,511.1 |  | 0 | 43511.1 | ELOUADRHIRI L | 1 | 1 | D | LATIFA E | 11-026 |  | 100 |  |  | 0 | 43511.1 | 4351110 |  |  |  |  |  |  |  |  | MP | 11-002 | 11-029 |  |  |  |  |  |  |  |
| 14244015 |  | Vend Fab - Optional Power Supply 750W (QTY5) |  | 195d | 2011-12-05 A | 2012-09-17 A | 14244010 FS-130d | 100% |  |  |  |  |  |  | PROCUREMENT<$50K 60 | 6,842.53 |  | 0 | 6842.53 | ELOUADRHIRI L | 1 | 1 | D | LATIFA E | 11-026 |  | 100 |  |  | 0 | 6842.53 | 684253 |  |  |  |  |  |  |  |  |  | 11-002 | 11-029 |  |  |  |  |  |  |  |
| 14244040 |  | Re-Baseline Actuals Adjustment |  | 1d | 2013-08-30 A | 2013-08-30 A |  | 100% |  | 2013-09-03 | 2013-09-03 |  |  |  | PROCUREMENT>$50K 69 NO ESCALATION | -26,658.33 |  |  |  |  |  |  |  |  |  |  | 100 | ADJ |  |  |  |  |  |  |  |  |  |  |  |  |  |  |  |  |  |  |  |  |  |  |
| 24244030 |  | CAEN 1527 HV mainframes install (12) (FC), (2) (SF)installation |  | 128d | 2014-10-01 | 2015-04-13 | 9-155M |  |  |  |  | 176d | 269d | 8/5 M-F w/JLAB Holidays ReBaseline | PLABOR | 13,001.94 |  |  | 0 | ELOUADRHIRI L | 1 | 1 | S | LATIFA E | 11-026 |  |  |  | 24244030 |  |  |  | IN |  | 12-054 | 13-002F |  | 13-015 | PR | 14-001 |  | 11-002 | 11-029 | ST | 12-007 | PE |  |  |  |  |
| 24244035 |  | HV mainframes SY4525 (5) Procurements |  | 184d | 2014-10-01 | 2015-07-02 | 9-155M |  |  |  |  | 120d | 213d | 8/5 M-F w/JLAB Holidays ReBaseline | PROCUREMENT<$50K 60 | 50,000 |  |  | 0 | ELOUADRHIRI L | 1 | 1 | U | LATIFA E | 11-026 |  | 100 |  | 24244035 | 50000 | 0 | 0 | IN |  | 12-054 | 13-002F | PE | 13-015 | PR |  |  | 11-002 | 11-029 |  | 12-007 |  | PE |  |  |  |
|  | 5 | **1.4.2.4.5 PRE-TRIGGER** |  |  |  |  |  |  |  |  |  |  |  |  |  |  |  |  |  |  |  |  |  |  |  |  |  |  |  |  |  |  |  |  |  |  |  |  |  |  |  |  |  |  |  |  |  |  |  |  |
|  | 6 | **1.4.2.4.6 LOGIC** |  |  |  |  |  |  |  |  |  |  |  |  |  |  |  |  |  |  |  |  |  |  |  |  |  |  |  |  |  |  |  |  |  |  |  |  |  |  |  |  |  |  |  |  |  |  |  |  |
|  | 7 | **1.4.2.4.7 CRATES, RACKS** |  |  | 2010-09-13 | 2014-12-15 |  |  |  |  |  |  |  |  |  |  |  |  |  |  |  |  |  |  |  |  |  |  |  |  |  |  |  |  |  |  |  |  |  |  |  |  |  |  |  |  |  |  |  |  |
| 14247005 |  | Crates & Racks Prcrmnt |  | 8d | 2010-09-13 A | 2010-09-22 A | 12224005, 9-120M FS+40d | 100% |  |  |  |  |  |  | SCIENTIST [40 h]; ELEC TECH [80 h] | 5,968.4 | 5,968.4 | 0 | 6557.6 | ELOUADRHIRI L | 1 | 1 | H | LATIFA E | 11-026 |  |  |  |  |  |  |  |  |  |  |  |  |  |  |  |  |  |  |  | 12-007 |  |  | 10-077 |  |  |
| 14247008 |  | Vend Fab Crates and Racks Phase 1 Peg Point #2 VME64X Qty 5 |  | 117d | 2010-09-30 A | 2011-03-25 A | 9-110M FS-1d | 100% |  |  |  |  |  |  | PROCUREMENT<$50K 60 NO ESCALATION FY11; PROCUREMENT>$50K 69 NO ESCALATION FY11 | 36,160 |  | 0 | 36160 | ELOUADRHIRI L | 1 | 1 | D | LATIFA E | 11-026 |  | 100 |  |  | 0 | 36160 | 3616000 | IN |  |  |  |  |  |  |  |  |  |  |  |  |  |  | 10-077 | 10-053 |  |
| 14247009 |  | Vend Fab Crates and Racks Phase 1 Peg Point #4 VXS Qty 5 |  | 162d | 2010-09-30 A | 2011-05-28 A | 14247008 FS-98d | 100% |  | 2010-09-30 | 2011-05-27 |  |  |  | PROCUREMENT<$50K 60 NO ESCALATION FY11; PROCUREMENT>$50K 69 NO ESCALATION FY11 | 54,340 |  | 0 | 54340 | ELOUADRHIRI L | 1 | 1 | D | LATIFA E | 11-026 |  | 100 |  |  | 0 | 54340 | 5434000 | IN |  |  |  |  |  |  |  |  |  |  |  |  |  |  | 10-077 | 10-053 |  |
| 14247010 |  | Vend Fab Crates and Racks Phase 2 VXS |  | 285d | 2011-11-01 A | 2012-12-17 A | 9-120M FS+41d, 14247009 | 100% |  | 2011-11-01 | 2012-12-31 |  |  |  | PROCUREMENT>$50K 69 NO ESCALATION; PROCUREMENT<$50K 60 NO ESCALATION | 198,417 |  | 0 | 198417 | ELOUADRHIRI L | 1 | 1 | D | LATIFA E | 11-026 |  | 100 |  |  | 0 | 198417 | 19841700 |  |  |  |  |  |  |  |  |  |  |  |  |  |  |  | 10-077 | 10-053 |  |
| 14247015 |  | Vend Fab Crates and Racks Phase 2 VME64X |  | 110d | 2011-11-01 A | 2012-04-16 A | 9-120M FS+41d, 14247009 | 100% |  |  |  |  |  |  | PROCUREMENT>$50K 69 NO ESCALATION | 104,355 |  | 0 | 104355 | ELOUADRHIRI L | 1 | 1 | D | LATIFA E | 11-026 |  | 100 |  |  | 0 | 104355 | 10435500 | IN |  |  |  |  |  |  |  |  |  |  |  |  |  |  | 10-077 | 10-053 |  |
| 14247020 |  | NIM crates (10) procurement |  | 130d | 2012-07-02 A | 2013-02-11 A | 9-130M FS-50d | 100% |  | 2012-07-02 | 2013-01-10 |  |  |  | PROCUREMENT<$50K 60; PROCUREMENT>$50K 69 | 72,233 |  | 0 | 72233 | ELOUADRHIRI L | 1 | 1 | D | LATIFA E |  | XX | 100 |  |  | 0 | 72233 | 7223300 | IN |  | 12-054F |  |  |  |  |  |  |  |  |  | 12-007 |  |  |  |  |  |
| 14247030 |  | Racks FC Level-0 (10) procurement |  | 36d | 2012-07-02 A | 2012-08-20 A | 9-130M FS-50d | 100% |  |  |  |  |  |  | PROCUREMENT<$50K 60; PROCUREMENT>$50K 69 | 72,233 |  | 0 | 72233 | ELOUADRHIRI L | 1 | 1 | D | LATIFA E |  |  | 100 |  |  | 0 | 72233 | 7223300 | IN |  | 12-054F |  |  |  |  |  |  |  |  |  | 12-007 |  |  |  |  |  |
| 14247006 |  | Wiener VME64x crates install (20) |  | 20d | 2013-08-30 A | 2013-08-30 A | 9-130M FS+163d | 100% |  | 2013-09-03 | 2013-09-30 |  |  |  | ELEC TECH [40 h] | 1,821.6 | 1,821.6 | 1821.6 | 1821.6 | ELOUADRHIRI L | 1 | 1 | U | LATIFA E |  |  |  |  |  |  |  |  |  |  | 12-054 |  |  |  |  |  |  |  |  |  | 12-007 |  |  |  |  |  |
| 14247025 |  | NIM crates (10) install |  | 20d | 2013-08-30 A | 2013-08-30 A | 14247020 FS+123d | 100% |  | 2013-09-03 | 2013-09-30 |  |  |  | ELEC TECH [16 h] | 728.64 | 728.64 | 728.64 | 728.64 | ELOUADRHIRI L | 1 | 1 | U | LATIFA E |  |  |  |  |  |  |  |  | IN |  | 12-054 |  |  |  |  |  |  |  |  |  | 12-007 |  |  |  |  |  |
| 14247035 |  | Racks FC Level-0 (10) install |  | 20d | 2013-08-30 A | 2013-08-30 A | 14247030 FS+194d | 100% |  | 2013-09-03 | 2013-09-30 |  |  |  | ELEC TECH [16 h] | 728.64 | 728.64 | 728.64 | 728.64 | ELOUADRHIRI L | 1 | 1 | U | LATIFA E |  |  |  |  |  |  |  |  | IN |  | 12-054 |  |  |  |  |  |  |  |  |  | 12-007 |  |  |  |  |  |
| 14247065 |  | Re-Baseline Actuals Adjustment |  | 1d | 2013-08-30 A | 2013-08-30 A |  | 100% |  | 2013-09-03 | 2013-09-03 |  |  |  | PROCUREMENT>$50K 69 NO ESCALATION | 61,081.12 |  |  | 61081.12 |  |  |  |  |  |  |  | 100 | ADJ |  | 0 | 61081.12 | 6108112 |  |  |  |  |  |  |  |  |  |  |  |  |  |  |  |  |  |  |
| 24247040 |  | Uninterruptible PowerSupply (16kVA) |  | 77d | 2013-09-03 A | 2013-12-20 | 9-130M FS+228d |  | 34d | 2013-10-01 | 2014-01-30 | 474d | 0d | 8/5 M-F w/JLAB Holidays ReBaseline | PROCUREMENT<$50K 60 NO ESCALATION FY14 | 12,382.92 |  |  | 0 | ELOUADRHIRI L | 1 | 1 | D | LATIFA E |  |  | 100 |  | 24247040 | 12382.92 | 0 | 0 | IN |  | 12-054 | 13-002F | EV | 13-015 | PR |  |  |  |  |  | 12-007 |  |  |  |  | OB |
| 24247045 |  | Re-locate existing UPS to Hall B |  | 20d | 2014-01-02 | 2014-01-30 | 24247040 |  |  |  |  | 474d | 222d | 8/5 M-F w/JLAB Holidays ReBaseline | PLABOR | 3,714.84 |  |  | 0 | ELOUADRHIRI L | 1 | 1 | S | LATIFA E |  |  |  |  | 24247045 |  |  |  | IN |  | 12-054 | 13-002F |  | 13-015 | PR | 14-001 |  |  |  | ST | 12-007 | PE |  |  |  |  |
| 24247005 |  | Wiener VME64x crates install (20) (FC) |  | 119d | 2014-01-03 | 2014-06-20 | 9-140M FS+60d |  |  |  |  | 252d | 0d | 8/5 M-F w/JLAB Holidays ReBaseline | PLABOR | 11,144.52 |  |  | 0 | ELOUADRHIRI L | 1 | 1 | S | LATIFA E |  |  |  |  | 24247005 |  |  |  |  |  | 12-054 | 13-002F |  | 13-015 | PR | 14-001 |  |  |  | ST | 12-007 | PE |  |  |  |  |
| 24247025 |  | NIM crates (10) install (FC) |  | 127.5d | 2014-01-03 | 2014-07-03 | 9-140M FS+60d |  |  |  |  | 365.5d | 113.5d | 8/5 M-F w/JLAB Holidays ReBaseline | PLABOR | 7,429.68 |  |  | 0 | ELOUADRHIRI L | 1 | 1 | S | LATIFA E |  |  |  |  | 24247025 |  |  |  | IN |  | 12-054 | 13-002F |  | 13-015 | PR | 14-001 |  |  |  | ST | 12-007 | PE |  |  |  |  |
| 24247030 |  | NIM crates (2) install (SF) |  | 127.5d | 2014-03-31 | 2014-09-29 | 9-140M FS+119d |  |  |  |  | 305.5d | 53.5d | 8/5 M-F w/JLAB Holidays ReBaseline | PLABOR | 1,857.42 |  |  | 0 | ELOUADRHIRI L | 1 | 1 | S | LATIFA E |  |  |  |  | 24247030 |  |  |  | IN |  | 12-054 | 13-002F |  | 13-015 | PR | 14-001 |  |  |  | ST | 12-007 | PE |  |  |  |  |
| 24247005a |  | Wiener VME64x crates install (2) (SF) |  | 122d | 2014-06-23 | 2014-12-15 | 24247005 |  |  |  |  | 252d | 0d | 8/5 M-F w/JLAB Holidays ReBaseline | PLABOR | 1,857.42 |  |  | 0 | ELOUADRHIRI L | 1 | 1 | S | LATIFA E |  |  |  |  | 24247005a |  |  |  |  |  | 12-054 | 13-002F |  | 13-015 | PR | 14-001 |  |  |  | ST | 12-007 | PE |  |  |  |  |
| 24247060M |  | Crates and Racks Complete | milestone | 0d | 2014-12-15 | 2014-12-15 | 24247045, 24247030, 24247025, 24247005a, 24247005 |  |  |  |  | 252d | 345d | 8/5 M-F w/JLAB Holidays ReBaseline |  |  |  |  | 0 | ELOUADRHIRI L | 1 | 1 | M | LATIFA E |  |  |  |  | 24247060M |  |  |  | IN |  | 12-054 | 13-002F |  | 13-015 | PR |  |  |  |  |  | 12-007 |  |  |  |  |  |

Notes:
- 24244030: Steps: Install CAEN mainframes in the Hall and populate with HV boards; Connect and configure mainframes to the network, and boards to detectors; Include mainframes into epics IOCs and test entire system
- 24247045: Steps: Relocate UPS devices to the Pie Tower and Space Frame in Hall B; Replace all batteries; Connect to the network and emergency generator; Run tests
- 24247005: Steps: Install WIENER crates on Forward Carriage; Connect crates to the network and configure; Test crates with epics control
- 24247025: Steps: Install NIM crates on Forward Carriage; Connect crates to the network and configure; Test crates with epics control
- 24247030: Steps: Install NIM crates on Space Frame; Connect crates to the network and configure; Test crates with epics control
- 24247005a: Steps: Install WIENER crates on Space Frame; Connect crates to the network and configure; Test crates with epics control

| ID | WBS | Activity | Duration | Start | Finish | Predecessors | Complete | Planned start | Planned finish | Total float | Free float | Calendar | Resources | Cost | Actual cost | Calculated Remaining Total Cost | MONTHLY EV COST | RESP - Responsibility | STRT%COMP for CM EVM | FNSH%COMP for CM EVM | EVMS Reporting Codes | CAM RESPONSIBLE | CR 11-026 | CR 12-013 | Claimed Material Divider | ReBaseline Actuals Adjustment | PHAS - Project Phase | Activities with Steps | Remaining Material Cost Based on % Compl | Claimed Material Cost Based on % Complet | Initial Claimed Material Calc | Original Activity ID Rebaseline | CR 13-002 | BOE Expenses | CR 13-015 | Post Rebaseline | CR 14-001 | BOE Labor | BOE Procurement |
| --- | --- | --- | --- | --- | --- | --- | --- | --- | --- | --- | --- | --- | --- | --- | --- | --- | --- | --- | --- | --- | --- | --- | --- | --- | --- | --- | --- | --- | --- | --- | --- | --- | --- | --- | --- | --- | --- | --- | --- |
|  | 5 | **1.4.2.5 BEAMLINE** |  | 2012-02-01 | 2015-10-01 |  |  |  |  |  |  |  |  |  |  |  |  |  |  |  |  |  |  |  |  |  |  |  |  |  |  |  |  |  |  |  |  |  |  |
|  | 1 | **1.4.2.5.1 FARADAY CUP UPGRADE** |  | 2013-08-30 | 2013-08-30 |  |  |  |  |  |  |  |  |  |  |  |  |  |  |  |  |  |  |  |  |  |  |  |  |  |  |  |  |  |  |  |  |  |  |
| 14251005 |  | Refurb CLAS Faraday Cup | 80d | 2013-08-30 A | 2013-08-30 A | 9-140M, 9-130M FS+60d | 100% | 2013-10-01 | 2014-01-31 |  |  |  | MECH TECH [480 h]; ELEC ENG [240 h]; SCIENTIST [200 h]; MSHOP | 106,911.19 | 54,059.2 | 105189.59 | 105189.59 | ELOUADRHIRI L | 1 | 1 | U | LATIFA E | 11-026 | 12-013 |  |  |  |  |  |  |  |  |  |  |  |  |  |  |  |
| 14251010 |  | Re-Baseline Actuals Adjustment | 1d | 2013-08-30 A | 2013-08-30 A |  | 100% | 2013-09-03 | 2013-09-03 |  |  |  | PROCUREMENT>$50K 69 NO ESCALATION | -105,189.59 |  |  |  |  |  |  |  |  |  |  | 100 | ADJ |  |  |  |  |  |  |  |  |  |  |  |  |  |
|  | 2 | **1.4.2.5.2 MOLLER POLARIMETER UPGRADE** |  | 2013-08-30 | 2013-08-30 |  |  |  |  |  |  |  |  |  |  |  |  |  |  |  |  |  |  |  |  |  |  |  |  |  |  |  |  |  |  |  |  |  |  |
| 14252005 |  | Fab a Moller Polarimeter Supprt Struct | 120d | 2013-08-30 A | 2013-08-30 A | 9-140M, 12225020, 9-130M FS+60d | 100% | 2013-10-01 | 2014-03-31 |  |  |  | MECH TECH [220 h]; ELEC TECH [120 h]; SCIENTIST [20 h]; MSHOP; CONTRB UNIV LBR [880 h] | 30,012.45 | 17,011.2 | 29470.85 | 29470.85 | ELOUADRHIRI L | 1 | 1 | H | LATIFA E | 11-026 | 12-013 |  |  |  |  |  |  |  |  |  |  |  |  |  |  |  |
| 14252010 |  | Fab a Moller Polarimeter Supprt Struct | 120d | 2013-08-30 A | 2013-08-30 A | 9-140M, 14252005, 9-110M | 100% | 2014-04-01 | 2014-09-18 |  |  |  | ELEC TECH [48 h]; CONTRB UNIV LBR [352 h]; MSHOP; SCIENTIST [8 h]; MECH TECH [88 h] | 12,265.76 | 6,804.48 | 30122.8 | 12049.12 | ELOUADRHIRI L | 1 | 1 | H | LATIFA E | 11-026 | 12-013 |  |  |  |  |  |  |  |  |  |  |  |  |  |  |  |
| 14252015 |  | Re-Baseline Actuals Adjustment | 1d | 2013-08-30 A | 2013-08-30 A |  | 100% | 2013-09-03 | 2013-09-03 |  |  |  | PROCUREMENT>$50K 69 NO ESCALATION | -41,519.97 |  |  |  |  |  |  |  |  |  |  | 100 | ADJ |  |  |  |  |  |  |  |  |  |  |  |  |  |
|  | 3 | **1.4.2.5.3 TARGETS** |  |  |  |  |  |  |  |  |  |  |  |  |  |  |  |  |  |  |  |  |  |  |  |  |  |  |  |  |  |  |  |  |  |  |  |  |  |
|  | 4 | **1.4.2.5.4 BEAMLINE COMPONENTS** |  | 2012-02-01 | 2015-10-01 |  |  |  |  |  |  |  |  |  |  |  |  |  |  |  |  |  |  |  |  |  |  |  |  |  |  |  |  |  |  |  |  |  |  |
| 14254005 |  | P-#1 Constrctn of Beam Line Monitoring Sys | 32d | 2012-02-01 A | 2012-03-19 A | 9-120M | 100% | 2012-02-01 | 2012-03-16 |  |  |  | SCIENTIST [80 h] | 5,648.8 | 5,648.8 | 0 | 5648.8 | ELOUADRHIRI L | 1 | 1 | H | LATIFA E | 11-026 |  |  |  |  |  |  |  |  |  |  |  |  |  |  |  |  |
| 14254007 |  | Beamline Studies and Drawings | 149d | 2013-08-30 A | 2013-08-30 A | 9-120M FS+184d, 9-130M FS+60d, 9-140M | 100% | 2013-10-01 | 2014-05-09 |  |  |  | SCIENTIST [440 h]; MECH DES [220 h] | 44,365.2 | 42,994.6 | 41665.8 | 41665.8 | ELOUADRHIRI L | 1 | 1 | S | LATIFA E | 11-026 | 12-013 |  |  | IN | ST |  |  |  |  |  |  |  |  |  |  |  |
| 14254008 |  | MOU with FIU on Moller Polarimeter | 149d | 2013-08-30 A | 2013-08-30 A | 9-140M, 9-130M FS+60d, 9-120M FS+184d | 100% | 2013-10-01 | 2014-05-09 |  |  |  | SCIENTIST [440 h]; MECH DES [220 h] | 44,365.2 | 42,994.6 | 41665.8 | 41665.8 | ELOUADRHIRI L | 1 | 1 | S | LATIFA E | 11-026 | 12-013 |  |  | IN | ST |  |  |  |  |  |  |  |  |  |  |  |
| 14254010 |  | Constrctn of Beam Line Shielding | 120d | 2013-08-30 A | 2013-08-30 A | 9-130M FS+60d, 9-140M, 12225050 | 100% | 2013-10-01 | 2014-03-31 |  |  |  | PROCUREMENT<$50K 60; MSHOP | 56,913.48 |  | 56913.48 | 56913.48 | ELOUADRHIRI L | 1 | 1 | H | LATIFA E | 11-026 | 12-013 | 100 |  |  |  | 0 | 32766.91 | 3276691 |  |  |  |  |  |  |  |  |
| 14254015 |  | Constrctn of Beam Line Vac Sys | 120d | 2013-08-30 A | 2013-08-30 A | 9-130M FS+60d, 9-140M | 100% | 2013-10-01 | 2014-03-31 |  |  |  | MSHOP; PROCUREMENT<$50K 60; MECH TECH [181 h]; ELEC DES [181 h]; SCIENTIST [65.8 h]; VISTNG USERS [378.3 h] | 80,344.49 | 30,075.66 | 79385.003 | 79385.003 | ELOUADRHIRI L | 1 | 1 | U | LATIFA E | 11-026 | 12-013 | 100 |  |  |  | 0 | 31149.09 | 3114909 |  |  |  |  |  |  |  |  |
| 14254020 |  | P-#2 Constrctn of Beam Line Monitoring Sys | 120d | 2013-08-30 A | 2013-08-30 A | 9-130M FS+120d, 9-140M, 14254005 | 100% | 2013-10-01 | 2014-03-31 |  |  |  | SCIENTIST [144 h] | 10,825.92 | 10,491.84 | 11657.6 | 10491.84 | ELOUADRHIRI L | 1 | 1 | H | LATIFA E | 11-026 | 12-013 |  |  |  |  |  |  |  |  |  |  |  |  |  |  |  |
| 14254025 |  | Constrctn of Beam Line Vac Sys | 120d | 2013-08-30 A | 2013-08-30 A | 14254015, 9-110M, 9-140M | 100% | 2014-04-01 | 2014-09-18 |  |  |  | VISTNG USERS [133.94 h]; MECH TECH [66.96 h]; ELEC DES [66.96 h]; SCIENTIST [18.28 h] | 10,901.77 | 10,564.73 | 26411.8115 | 10564.7246 | ELOUADRHIRI L | 1 | 1 | U | LATIFA E | 11-026 | 12-013 |  |  |  |  |  |  |  |  |  |  |  |  |  |  |  |
| 14254030 |  | Re-Baseline Actuals Adjustment | 1d | 2013-08-30 A | 2013-08-30 A |  | 100% | 2013-09-03 | 2013-09-03 |  |  |  | PROCUREMENT>$50K 69 NO ESCALATION | -246,335.38 |  |  |  |  |  |  |  |  |  |  | 100 | ADJ |  |  |  |  |  |  |  |  |  |  |  |  |  |
| 24254000 |  | Faraday Cup Materials | 57d | 2014-10-01 | 2014-12-22 | 9-155M |  |  |  | 207d | 0d | 8/5 M-F w/JLAB Holidays ReBaseline | SUPPLIES & MATERIALS | 2,063.8 |  |  | 0 | ELOUADRHIRI L | 1 | 1 | D | LATIFA E | 11-026 | 12-013 |  |  | IN |  |  |  |  | 24254000 | 13-002F | PE | 13-015 | PR | 14-001 |  |  |
| 24254040 |  | Moller Shielding Manufacturing Design | 64d | 2014-10-01 | 2015-01-12 | 9-155M |  |  |  | 98d | 0d | 8/5 M-F w/JLAB Holidays ReBaseline | MECH DES [160 h]; MECH ENG [40 h] | 11,194.8 |  |  | 0 | ELOUADRHIRI L | 1 | 1 | S | LATIFA E | 11-026 | 12-013 |  |  | IN |  |  |  |  | 24254040 | 13-002F |  | 13-015 | PR | 14-001 | PE |  |
| 24254055 |  | Downstream Vacuum System Procurement | 57d | 2014-10-01 | 2014-12-22 | 9-155M |  |  |  | 206d | 0d | 8/5 M-F w/JLAB Holidays ReBaseline | PROCUREMENT<$50K 60 | 30,957 |  |  | 0 | ELOUADRHIRI L | 1 | 1 | D | LATIFA E | 11-026 | 12-013 | 100 |  |  |  | 30957 | 0 | 0 | 24254055 | 13-002F |  | 13-015 | PR | 14-001 |  | PE |
| 24254065 |  | Upstream Vacuum System Procurement | 57d | 2014-10-01 | 2014-12-22 | 9-155M |  |  |  | 227d | 0d | 8/5 M-F w/JLAB Holidays ReBaseline | PROCUREMENT<$50K 60 | 30,957 |  |  | 0 | ELOUADRHIRI L | 1 | 1 | D | LATIFA E | 11-026 | 12-013 | 100 |  | IN |  | 30957 | 0 | 0 | 24254065 | 13-002F |  | 13-015 | PR | 14-001 |  | PE |
| 24254075 |  | Beam Offset Monitor Procurement | 57d | 2014-10-01 | 2014-12-22 | 9-155M |  |  |  | 207d | 0d | 8/5 M-F w/JLAB Holidays ReBaseline | PROCUREMENT<$50K 60 | 8,255.2 |  |  | 0 | ELOUADRHIRI L | 1 | 1 | D | LATIFA E | 11-026 | 12-013 | 100 |  | IN |  | 8255.2 | 0 | 0 | 24254075 | 13-002F |  | 13-015 | PR | 14-001 |  | PE |
| 24254085 |  | 2C24 girder move Procurement | 57d | 2014-10-01 | 2014-12-22 | 9-155M |  |  |  | 238d | 0d | 8/5 M-F w/JLAB Holidays ReBaseline | PROCUREMENT<$50K 60 | 10,319 |  |  | 0 | ELOUADRHIRI L | 1 | 1 | D | LATIFA E | 11-026 | 12-013 | 100 |  | IN |  | 10319 | 0 | 0 | 24254085 | 13-002F |  | 13-015 | PR | 14-001 |  | PE |
| 24254095 |  | Upstream beam blocker and vacuum box Manufacturing Design | 41d | 2014-10-01 | 2014-11-26 | 9-155M |  |  |  | 79d | 0d | 8/5 M-F w/JLAB Holidays ReBaseline | MECH DES [160 h]; MECH ENG [40 h] | 11,194.8 |  |  | 0 | ELOUADRHIRI L | 1 | 1 | S | LATIFA E | 11-026 | 12-013 |  |  |  |  |  |  |  | 24254095 | 13-002F |  | 13-015 | PR | 14-001 | PE |  |
| 24254110 |  | Upstream Shielding Wall Procurement | 146d | 2014-10-01 | 2015-05-07 | 9-155M |  |  |  | 158d | 0d | 8/5 M-F w/JLAB Holidays ReBaseline | PROCUREMENT<$50K 60; PROCUREMENT>$50K 69 | 59,381.4 |  |  | 0 | ELOUADRHIRI L | 1 | 1 | D | LATIFA E | 11-026 | 12-013 | 100 |  | IN |  | 59381.4 | 0 | 0 | 24254110 | 13-002F |  | 13-015 | PR | 14-001 |  | PE |
| 24254120 |  | Procurement of Beamline Devices | 247d | 2014-10-01 | 2015-10-01 | 9-155M |  |  |  | 152d | 0d | 8/5 M-F w/JLAB Holidays ReBaseline | PROCUREMENT<$50K 60 | 20,638 |  |  | 0 | ELOUADRHIRI L | 1 | 1 | D | LATIFA E | 11-026 | 12-013 | 100 |  | IN |  | 20638 | 0 | 0 | 24254120 | 13-002F |  | 13-015 | PR | 14-001 |  | PE |
| 24254090 |  | 2C24 girder move Labor | 59d | 2014-10-10 | 2015-01-14 | 24254085 FS-50d |  |  |  | 238d | 331d | 8/5 M-F w/JLAB Holidays ReBaseline | MECH TECH [360 h] | 17,035.2 |  |  | 0 | ELOUADRHIRI L | 1 | 1 | S | LATIFA E | 11-026 | 12-013 |  |  |  |  |  |  |  | 24254090 | 13-002F |  | 13-015 | PR | 14-001 | PE |  |
| 24254010 |  | Downstream Viewer Manufacturing Design | 61d | 2014-11-26 | 2015-03-05 | 9-155M FS+40d |  |  |  | 103d | 0d | 8/5 M-F w/JLAB Holidays ReBaseline | MECH DES [40 h] | 2,052 |  |  | 0 | ELOUADRHIRI L | 1 | 1 | H | LATIFA E | 11-026 | 12-013 |  |  | IN |  |  |  |  | 24254010 | 13-002F |  | 13-015 | PR | 14-001 | PE |  |
| 24254025 |  | Moller polarimeter upgrade Manufacturing Design | 61d | 2014-11-26 | 2015-03-05 | 9-155M FS+40d |  |  |  | 103d | 0d | 8/5 M-F w/JLAB Holidays ReBaseline | MECH DES [160 h]; MECH ENG [40 h] | 11,194.8 |  |  | 0 | ELOUADRHIRI L | 1 | 1 | S | LATIFA E | 11-026 | 12-013 |  |  |  |  |  |  |  | 24254025 | 13-002F |  | 13-015 | PR | 14-001 | PE |  |
| 24254100 |  | Upstream beam blocker and vacuum box Procurement | 84d | 2014-12-01 | 2015-04-08 | 24254095 |  |  |  | 79d | 0d | 8/5 M-F w/JLAB Holidays ReBaseline | PROCUREMENT<$50K 60; PROCUREMENT>$50K 69 | 51,595 |  |  | 0 | ELOUADRHIRI L | 1 | 1 | D | LATIFA E | 11-026 | 12-013 | 100 |  | IN |  | 51595 | 0 | 0 | 24254100 | 13-002F |  | 13-015 | PR | 14-001 |  | PE |
| 24254005 |  | Faraday Cup Labor | 40d | 2014-12-23 | 2015-02-27 | 24254000 |  |  |  | 207d | 300d | 8/5 M-F w/JLAB Holidays ReBaseline | ELEC ENG [40 h]; ELEC TECH [80 h] | 6,764.4 |  |  | 0 | ELOUADRHIRI L | 1 | 1 | H | LATIFA E | 11-026 | 12-013 |  |  | IN |  |  |  |  | 24254005 | 13-002F |  | 13-015 | PR | 14-001 | PE |  |
| 24254060 |  | Downstream Vacuum System Installation | 41d | 2014-12-23 | 2015-03-02 | 24254055 |  |  |  | 206d | 299d | 8/5 M-F w/JLAB Holidays ReBaseline | MECH TECH [160 h] | 7,571.2 |  |  | 0 | ELOUADRHIRI L | 1 | 1 | H | LATIFA E | 11-026 | 12-013 |  |  |  |  |  |  |  | 24254060 | 13-002F |  | 13-015 | PR | 14-001 | PE |  |
| 24254070 |  | Upstream Vacuum System Installation | 20d | 2014-12-23 | 2015-01-30 | 24254065 |  |  |  | 227d | 320d | 8/5 M-F w/JLAB Holidays ReBaseline | MECH DES [40 h]; MECH TECH [40 h] | 3,944.8 |  |  | 0 | ELOUADRHIRI L | 1 | 1 | H | LATIFA E | 11-026 | 12-013 |  |  |  |  |  |  |  | 24254070 | 13-002F |  | 13-015 | PR | 14-001 | PE |  |
| 24254080 |  | Beam Offset Monitor Installation | 40d | 2014-12-23 | 2015-02-27 | 24254075 |  |  |  | 207d | 300d | 8/5 M-F w/JLAB Holidays ReBaseline | MECH DES [40 h]; MECH TECH [40 h]; ELEC ENG [80 h] | 9,955.2 |  |  | 0 | ELOUADRHIRI L | 1 | 1 | H | LATIFA E | 11-026 | 12-013 |  |  |  |  |  |  |  | 24254080 | 13-002F |  | 13-015 | PR | 14-001 | PE |  |
| 24254045 |  | Moller Shielding Procurement | 58d | 2015-01-13 | 2015-04-03 | 24254040 |  |  |  | 98d | 0d | 8/5 M-F w/JLAB Holidays ReBaseline | PROCUREMENT<$50K 60; PROCUREMENT>$50K 69 | 51,595 |  |  | 0 | ELOUADRHIRI L | 1 | 1 | D | LATIFA E | 11-026 | 12-013 | 100 |  | IN |  | 51595 | 0 | 0 | 24254045 | 13-002F |  | 13-015 | PR | 14-001 |  | PE |
| 24254015 |  | Downstream Viewer Procurement | 60d | 2015-03-06 | 2015-05-29 | 24254010 |  |  |  | 103d | 0d | 8/5 M-F w/JLAB Holidays ReBaseline | PROCUREMENT<$50K 60 | 10,319 |  |  | 0 | ELOUADRHIRI L | 1 | 1 | D | LATIFA E | 11-026 | 12-013 | 100 |  | IN |  | 10319 | 0 | 0 | 24254015 | 13-002F |  | 13-015 | PR | 14-001 |  | PE |
| 24254030 |  | Moller polarimeter upgrade Procurement | 60d | 2015-03-06 | 2015-05-29 | 24254025 |  |  |  | 103d | 0d | 8/5 M-F w/JLAB Holidays ReBaseline | PROCUREMENT<$50K 60; PROCUREMENT>$50K 69 | 61,914 |  |  | 0 | ELOUADRHIRI L | 1 | 1 | D | LATIFA E | 11-026 | 12-013 | 100 |  | IN |  | 61914 | 0 | 0 | 24254030 | 13-002F |  | 13-015 | PR | 14-001 |  | PE |
| 24254105 |  | Upstream beam blocker and vacuum box Installation | 120d | 2015-03-12 | 2015-08-31 | 24254100 FS-20d |  |  |  | 79d | 172d | 8/5 M-F w/JLAB Holidays ReBaseline | MECH TECH [160 h]; ELEC ENG [40 h] | 10,576.4 |  |  | 0 | ELOUADRHIRI L | 1 | 1 | S | LATIFA E | 11-026 | 12-013 |  |  | IN |  |  |  |  | 24254105 | 13-002F |  | 13-015 | PR | 14-001 | PE |  |
| 24254050 |  | Moller Shielding Installation | 84d | 2015-04-06 | 2015-08-04 | 24254045 |  |  |  | 98d | 191d | 8/5 M-F w/JLAB Holidays ReBaseline | MECH TECH [320 h] | 15,142.4 |  |  | 0 | ELOUADRHIRI L | 1 | 1 | S | LATIFA E | 11-026 | 12-013 |  |  | IN |  |  |  |  | 24254050 | 13-002F |  | 13-015 | PR | 14-001 | PE |  |
| 24254115 |  | Upstream Shielding Wall Installation | 20d | 2015-04-10 | 2015-05-07 | 24254110 FS-20d |  |  |  | 158d | 251d | 8/5 M-F w/JLAB Holidays ReBaseline | MECH DES [40 h]; MECH TECH [40 h]; ELEC ENG [80 h] | 9,955.2 |  |  | 0 | ELOUADRHIRI L | 1 | 1 | H | LATIFA E | 11-026 | 12-013 |  |  |  |  |  |  |  | 24254115 | 13-002F |  | 13-015 | PR | 14-001 | PE |  |
| 24254020 |  | Downstream Viewer Assembly | 57d | 2015-05-06 | 2015-07-28 | 24254015 FS-17d |  |  |  | 103d | 196d | 8/5 M-F w/JLAB Holidays ReBaseline | MECH TECH [40 h] | 1,892.8 |  |  | 0 | ELOUADRHIRI L | 1 | 1 | H | LATIFA E | 11-026 | 12-013 |  |  | IN |  |  |  |  | 24254020 | 13-002F |  | 13-015 | PR | 14-001 | PE |  |
| 24254035 |  | Moller polarimeter upgrade Installation | 57d | 2015-05-06 | 2015-07-28 | 24254030 FS-17d |  |  |  | 103d | 196d | 8/5 M-F w/JLAB Holidays ReBaseline | MECH TECH [284.44 h]; ELEC ENG [35.56 h] | 16,131.2 |  |  | 0 | ELOUADRHIRI L | 1 | 1 | S | LATIFA E | 11-026 | 12-013 |  |  | IN |  |  |  |  | 24254035 | 13-002F |  | 13-015 | PR | 14-001 | PE |  |

Notes:
- 14254007: Steps: Beamline Studies and Drawings (done)
- 14254008: Steps: MOU with FIU on Moller Polarimeter (done)

| ID | WBS | Activity | Type | Duration | Start | Finish | Predecessors | Complete | Remaining | Planned start | Planned finish | Total float | Free float | Calendar | Resources | Cost | Actual cost | Remaining Material Cost Based on % Compl | Claimed Material Cost Based on % Complet | Initial Claimed Material Calc | Claimed Material Divider | MONTHLY EV COST | ReBaseline Actuals Adjustment | Calculated Remaining Total Cost | RESP - Responsibility | STRT%COMP for CM EVM | FNSH%COMP for CM EVM | EVMS Reporting Codes | CAM RESPONSIBLE | CR 11-035 | CR 12-027 | CR 12-051 | PHAS - Project Phase | CR 08-016 | CR 09-012 | CR 09-030 | CR 09-030 Repair | CR 11-026 | LOE % Pre Calc | LOE % | LOE Divider | LOE Multiplier | CR 12-007 | MARCH!!! | CR 12-052 | CR 13-002 | Activities with Steps | CR 11-022 | CR 12-024 | Original Activity ID Rebaseline | PRIOR MONTH EV COST | BOE Labor | CR 13-015 | Post Rebaseline | BOE Procurement | Obligated Prior to Rebaseline |
| --- | --- | --- | --- | --- | --- | --- | --- | --- | --- | --- | --- | --- | --- | --- | --- | --- | --- | --- | --- | --- | --- | --- | --- | --- | --- | --- | --- | --- | --- | --- | --- | --- | --- | --- | --- | --- | --- | --- | --- | --- | --- | --- | --- | --- | --- | --- | --- | --- | --- | --- | --- | --- | --- | --- | --- | --- |
|  | 6 | **1.4.2.6 INFRASTRUCTURE** |  |  | 2011-07-01 | 2016-05-12 |  |  |  |  |  |  |  |  |  |  |  |  |  |  |  |  |  |  |  |  |  |  |  |  |  |  |  |  |  |  |  |  |  |  |  |  |  |  |  |  |  |  |  |  |  |  |  |  |  |  |
|  | 1 | **1.4.2.6.1 UTILITIES** |  |  | 2013-08-30 | 2013-08-30 |  |  |  |  |  |  |  |  |  |  |  |  |  |  |  |  |  |  |  |  |  |  |  |  |  |  |  |  |  |  |  |  |  |  |  |  |  |  |  |  |  |  |  |  |  |  |  |  |  |  |
| 14261000 |  | Re-Baseline Actuals Adjustment |  | 1d | 2013-08-30 A | 2013-08-30 A |  | 100% |  | 2013-09-03 | 2013-09-03 |  |  |  | PROCUREMENT>$50K 69 NO ESCALATION | 8,812.95 |  | 0 | 8812.95 | 881295 | 100 | 8812.95 | ADJ |  |  |  |  |  |  |  |  |  |  |  |  |  |  |  |  |  |  |  |  |  |  |  |  |  |  |  |  |  |  |  |  |  |
|  | 2 | **1.4.2.6.2 MECHANICAL FRAMES** |  |  |  |  |  |  |  |  |  |  |  |  |  |  |  |  |  |  |  |  |  |  |  |  |  |  |  |  |  |  |  |  |  |  |  |  |  |  |  |  |  |  |  |  |  |  |  |  |  |  |  |  |  |  |
|  | 3 | **1.4.2.6.3 ASSEMBLY** |  |  | 2013-08-30 | 2013-08-30 |  |  |  |  |  |  |  |  |  |  |  |  |  |  |  |  |  |  |  |  |  |  |  |  |  |  |  |  |  |  |  |  |  |  |  |  |  |  |  |  |  |  |  |  |  |  |  |  |  |  |
| 14263000 |  | Re-Baseline Actuals Adjustment |  | 1d | 2013-08-30 A | 2013-08-30 A |  | 100% |  | 2013-09-03 | 2013-09-03 |  |  |  | PROCUREMENT>$50K 69 NO ESCALATION | 41.41 |  | 0 | 41.41 | 4141 | 100 | 41.41 | ADJ |  |  |  |  |  |  |  |  |  |  |  |  |  |  |  |  |  |  |  |  |  |  |  |  |  |  |  |  |  |  |  |  |  |
|  | 4 | **1.4.2.6.4 INSTALLATION** |  |  | 2011-07-01 | 2016-05-12 |  |  |  |  |  |  |  |  |  |  |  |  |  |  |  |  |  |  |  |  |  |  |  |  |  |  |  |  |  |  |  |  |  |  |  |  |  |  |  |  |  |  |  |  |  |  |  |  |  |  |
| 14264007x |  | Subway Addition Procurement Prep |  | 80d | 2011-07-01 A | 2011-10-24 A | 9-110M FS+185d | 100% |  |  |  |  |  |  | PLANT ENG [160 h]; MECH DES [80 h] | 14,718.88 | 14,718.88 |  |  |  |  | 14625.6 |  | 0 | ELOUADRHIRI L | 1 | 1 | H | LATIFA E | 11 -035 | 12-027F | 12-051F |  |  |  |  |  |  |  |  |  |  |  |  |  |  |  |  |  |  |  |  |  |  |  |  |
| 14264009 |  | Electrical Utilities Mods of Spaceframe |  | 9d | 2011-07-06 A | 2011-07-18 A | 9-110M FS+205d | 100% |  |  |  |  |  |  | PROCUREMENT<$50K 60 | 38,000 |  | 0 | 38000 | 3800000 | 100 | 38000 |  | 0 | ELOUADRHIRI L | 1 | 1 | D | LATIFA E | 11 -035 | 12-027F | 12-051F | IN | 08-016 | 09-012 | 09-030 | 09-030 | 11-026 |  |  |  |  |  |  |  |  |  |  |  |  |  |  |  |  |  |  |
| 14264001LOE |  | Installation Procurement Support |  | 247d | 2011-10-03 A | 2012-09-28 A | 9-120M | 100% |  |  |  |  |  |  | MECH TECH [880 h] | 39,107.2 | 39,107.2 |  |  |  |  | 39107.2 |  | 0 | ELOUADRHIRI L | 1 | 1 | E | LATIFA E | 11 -035 |  |  |  |  |  | 09-030 | 09-030 | 11-026 | 7.69230769 | 92.3076923 | 100 | 100 |  |  |  |  |  |  |  |  |  |  |  |  |  |  |
| 14264008a |  | Spaceframe Motion System |  | 16d | 2011-10-03 A | 2011-10-24 A | 9-110M FS+290d | 100% |  |  |  |  |  |  | PROCUREMENT<$50K 60 NO ESCALATION FY12 | 50,000 |  | 0 | 50000 | 5000000 | 100 | 50000 |  | 0 | ELOUADRHIRI L | 1 | 1 | D | LATIFA E | 11 -035 |  | 12-051F | IN | 08-016 | 09-012 | 09-030 | 09-030 | 11-026 |  |  |  |  |  |  |  |  |  |  |  |  |  |  |  |  |  |  |
| 14264000aLOE |  | Installation Engineering Oversight A FY12 |  | 206d | 2011-12-01 A | 2012-09-28 A | 9-120M FS+41d | 100% |  |  |  |  |  |  | MECH ENG [1520 h] | 106,582.4 | 106,582.4 |  |  |  |  | 106582.4 |  | 0 | ELOUADRHIRI L | 1 | 1 | E | LATIFA E | 11 -035 |  |  |  |  |  | 09-030 | 09-030 | 11-026 | 9.22330097 | 90.77669902 | 100 | 100 | 12-007 |  |  |  |  |  |  |  |  |  |  |  |  |  |
| 14264000cLOE |  | Installation Engineering Oversight B FY12 |  | 169d | 2012-02-01 A | 2012-09-28 A | 9-120M FS+78d | 100% |  |  |  |  |  |  | MECH ENG [1220 h] | 85,546.4 | 85,546.4 |  |  |  |  | 85546.4 |  | 0 | ELOUADRHIRI L | 1 | 1 | E | LATIFA E | 11 -035 |  |  |  |  |  | 09-030 | 09-030 | 11-026 | 11.24260355 | 88.75739644 | 100 | 100 | 12-007 |  |  |  |  |  |  |  |  |  |  |  |  |  |
| 14264000 |  | CLAS 6 Removal |  | 177d | 2012-05-18 A | 2013-01-31 A | 2-02M | 100% |  | 2012-05-18 | 2013-02-06 |  |  |  |  |  |  |  |  |  |  | 0 |  |  | ELOUADRHIRI L | 1 | 1 | Z | LATIFA E | 11 -035 |  |  |  |  |  | 09-030 | 09-030 | 11-026 |  |  |  |  |  | XX |  |  |  |  |  |  |  |  |  |  |  |  |
| 14264008 |  | Vend Fab Subway Addition with rails and Spaceframe Mod |  | 178d | 2012-09-11 A | 2013-04-15 A | 9-120M FS+240d, 14264009, 14264007x | 100% |  | 2012-09-11 | 2013-05-31 |  |  |  | PROCUREMENT<$50K 60 NO ESCALATION; PROCUREMENT>$50K 69 NO ESCALATION | 277,129 |  | 0 | 277129 | 27712900 | 100 | 277129 |  | 0 | ELOUADRHIRI L | 1 | 1 | D | LATIFA E | 11 -035 | 12-027 | 12-051 | IN | 08-016 | 09-012 | 09-030 | 09-030 | 11-026 |  |  |  |  |  |  |  |  |  |  |  |  |  |  |  |  |  |  |
| 14264000bLOE |  | Installation Engineering Oversight A FY13 |  | 80d | 2012-10-01 A | 2013-01-31 A | 14264000aLOE | 100% |  |  |  |  |  |  | MECH ENG [580 h] | 41,968.8 | 41,968.8 |  |  |  |  | 41968.8 |  | 0 | ELOUADRHIRI L | 1 | 1 | E | LATIFA E | 11 -035 |  |  |  |  |  | 09-030 | 09-030 | 11-026 | 26.25 | 73.75 | 100 | 100 | 12-007 | XX |  |  |  |  |  |  |  |  |  |  |  |  |
| 14264000dLOE |  | Installation Engineering Oversight B FY13 |  | 80d | 2012-10-01 A | 2013-01-31 A | 14264000cLOE | 100% |  |  |  |  |  |  | MECH ENG [580 h] | 41,968.8 | 41,968.8 |  |  |  |  | 41968.8 |  | 0 | ELOUADRHIRI L | 1 | 1 | E | LATIFA E | 11 -035 |  |  |  |  |  | 09-030 | 09-030 | 11-026 | 26.25 | 73.75 | 100 | 100 | 12-007 | XX |  |  |  |  |  |  |  |  |  |  |  |  |
| 14264002LOE |  | Installation Procurement Support |  | 247d | 2012-10-01 A | 2013-08-30 A | 14264001LOE | 100% |  | 2012-10-01 | 2013-09-27 |  |  |  | MECH TECH [812.31 h] | 37,252.54 | 37,252.54 |  |  |  |  | 37252.5366 |  | 6699.2288 | ELOUADRHIRI L | 1 | 1 | E | LATIFA E | 11 -035 |  |  |  |  |  | 09-030 | 09-030 | 11-026 | 7.69230769 | 92.3076923 | 100 | 100 |  |  |  |  |  |  |  |  |  |  |  |  |  |  |
| 14264240 |  | Manufacturing Design of Fwd. Carriage Mods |  | 12d | 2012-12-03 A | 2013-02-21 A | 9-130M FS+43d | 100% |  | 2013-01-02 | 2013-01-17 |  |  |  | MECH DES [80 h] | 3,976.8 | 3,976.8 |  |  |  |  | 3976.8 |  | 0 | ELOUADRHIRI L | 1 | 1 | H | LATIFA E |  |  |  | IN |  |  |  |  |  |  |  |  |  |  | XX | 12-052 | 13-002 |  |  |  |  |  |  |  |  |  |  |
| 14264269 |  | Manufacturing Design of Motion System |  | 55d | 2012-12-03 A | 2013-02-21 A | 9-130M FS+60d | 100% |  | 2013-01-03 | 2013-03-22 |  |  |  | MECH DES [80 h] | 3,976.8 | 3,976.8 |  |  |  |  | 3976.8 |  | 0 | ELOUADRHIRI L | 1 | 1 | H | LATIFA E |  |  |  | IN |  |  |  |  |  |  |  |  |  |  |  | 12-052 | 13-002 |  |  |  |  |  |  |  |  |  |  |
| 14264271 |  | Procurement Prep of Motion System |  | 27d | 2013-02-01 A | 2013-02-22 A | 14264269 | 100% |  | 2013-04-19 | 2013-05-28 |  |  |  | MECH ENG [8 h] | 578.88 | 578.88 |  |  |  |  | 578.88 |  | 0 | ELOUADRHIRI L | 1 | 1 | H | LATIFA E |  |  |  | IN |  |  |  |  |  |  |  |  |  |  |  | 12-052 | 13-002 |  |  |  |  |  |  |  |  |  |  |
| 14264245 |  | Procurement Prep of Fwd. Carriage Mods |  | 25d | 2013-02-05 A | 2013-02-22 A | 14264240 | 100% |  | 2013-04-01 | 2013-05-03 |  |  |  | MECH ENG [8 h] | 578.88 | 578.88 |  |  |  |  | 578.88 |  | 0 | ELOUADRHIRI L | 1 | 1 | H | LATIFA E |  |  |  | IN |  |  |  |  |  |  |  |  |  |  |  | 12-052 | 13-002 |  |  |  |  |  |  |  |  |  |  |
| 14264315M |  | Start Installation of Hardware for DAQ | milestone | 0d | 2013-04-08 A | 2013-04-08 A | 14264002M FS+15d | 100% |  | 2013-05-22 | 2013-05-22 |  |  |  |  |  |  |  |  |  |  | 0 |  |  | ELOUADRHIRI L | 1 | 1 | M | LATIFA E | 11 -035 |  |  | IN | 08-016 | 09-012 | 09-030 | 09-030 | 11-026 |  |  |  |  |  |  | 12-052 | 13-002 |  |  |  |  |  |  |  |  |  |  |
| 14264316 |  | Removal of unused cables (DAQ) |  | 10d | 2013-04-08 A | 2013-04-22 A | 14264315M | 100% |  | 2013-05-22 | 2013-06-05 |  |  |  | ELEC TECH [160 h] | 7,286.4 | 7,286.4 |  |  |  |  | 7286.4 |  | 0 | ELOUADRHIRI L | 1 | 1 | H | LATIFA E | 11 -035 |  |  | IN |  |  | 09-030 | 09-030 | 11-026 |  |  |  |  |  |  | 12-052 | 13-002 |  |  |  |  |  |  |  |  |  |  |
| 14264013 |  | Vend Fab Fwd. carriage Mods and install hangers and mount |  | 141d | 2013-04-15 A | 2013-08-30 A | 9-130M, 14264245 FS-165d, 9-120M FS+163d | 100% |  | 2013-05-06 | 2013-11-21 |  |  |  | PROCUREMENT<$50K 60 NO ESCALATION FY13 | 40,000 |  | 0 | 40000 | 4000000 | 100 | 40000 |  | 8000 | ELOUADRHIRI L | 1 | 1 | D | LATIFA E | 11 -035 | 12-027 | 12-051 | IN |  |  | 09-030 | 09-030 | 11-026 |  |  |  |  |  |  |  | 13-002 |  |  |  |  |  |  |  |  |  |  |
| 14264362 |  | Vend Fab Fwd. Detector Installation Tooling |  | 141d | 2013-08-01 A | 2013-08-28 A | 9-130M FS+110d | 100% |  | 2013-08-01 | 2014-02-28 |  |  |  | PROCUREMENT<$50K 60 | 39,117.37 |  | 0 | 39117.36839 | 3911736.839 | 100 | 39117.36839 |  | 39117.36839 | ELOUADRHIRI L | 1 | 1 | D | LATIFA E | 11 -035 |  |  | IN |  |  | 09-030 | 09-030 | 11-026 |  |  |  |  |  |  | 12-052 | 13-002 |  |  |  |  |  |  |  |  |  |  |
| 14264278 |  | Install Motion system |  | 5d | 2013-08-26 A | 2013-08-30 A | 14264273, 14264265 | 100% |  | 2014-01-10 | 2014-01-16 |  |  |  |  |  |  |  |  |  |  | 0 |  |  | ELOUADRHIRI L | 1 | 1 | Z | LATIFA E |  |  |  | IN |  |  |  |  |  |  |  |  |  |  |  | 12-052 | 13-002 |  |  |  |  |  |  |  |  |  |  |
| 14264290 |  | Weld PCAL and LTCC brackets |  | 10d | 2013-08-26 A | 2013-08-30 A | 14264285 FS-228d | 100% |  | 2014-01-24 | 2014-02-06 |  |  |  | PLABOR; MECH TECH [80 h] | 20,874.28 | 3,668.8 |  |  |  |  | 20757.47676 |  | 20757.47676 | ELOUADRHIRI L | 1 | 1 | H | LATIFA E |  |  |  |  |  |  |  |  |  |  |  |  |  |  |  | 12-052 | 13-002 |  |  |  |  |  |  |  |  |  |  |
| 14264002M |  | Hall Cleared and Cleaned for CLAS12 installation | milestone | 0d | 2013-08-30 A | 2013-08-30 A | 2-07M, 2-02M, 14264000 | 100% |  | 2013-09-03 | 2013-09-03 |  |  |  |  |  |  |  |  |  |  | 0 |  |  | ELOUADRHIRI L | 1 | 1 | M | LATIFA E | 11 -035 |  |  |  |  |  | 09-030 | 09-030 | 11-026 |  |  |  |  |  | XX |  |  |  |  |  |  |  |  |  |  |  |  |
| 14264202M |  | R2 Drift Chambers Ready for Installation | milestone | 0d | 2013-08-30 A | 2013-08-30 A | 142213069 | 100% |  | 2013-09-03 | 2013-09-03 |  |  |  |  |  |  |  |  |  |  | 0 |  |  | ELOUADRHIRI L | 1 | 1 | M | LATIFA E |  |  |  |  |  |  |  |  |  |  |  |  |  |  |  | 12-052 | 13-002 |  |  |  |  |  |  |  |  |  |  |
| 14264204M |  | R1 Drift Chambers Ready for Installation | milestone | 0d | 2013-08-30 A | 2013-08-30 A | 142213100 | 100% |  | 2014-06-03 | 2014-06-03 |  |  |  |  |  |  |  |  |  |  | 0 |  |  | ELOUADRHIRI L | 1 | 1 | M | LATIFA E |  |  |  |  |  |  |  |  |  |  |  |  |  |  |  | 12-052 | 13-002 |  |  |  |  |  |  |  |  |  |  |
| 14264206M |  | ToF Panel 1a - First 3 units Ready for Installation | milestone | 0d | 2013-08-30 A | 2013-08-30 A | 142232455 FS+80d | 100% |  | 2013-09-03 | 2013-09-03 |  |  |  |  |  |  |  |  |  |  | 0 |  |  | ELOUADRHIRI L | 1 | 1 | M | LATIFA E |  |  |  |  |  |  |  |  |  |  |  |  |  |  |  | 12-052 | 13-002 |  |  |  |  |  |  |  |  |  |  |
| 14264220M |  | PCAL - First 5 units Ready for Installation | milestone | 0d | 2013-08-30 A | 2013-08-30 A | 142223560 | 100% |  | 2013-09-04 | 2013-09-04 |  |  |  |  |  |  |  |  |  |  | 0 |  |  | ELOUADRHIRI L | 1 | 1 | M | LATIFA E |  |  |  |  |  |  |  |  |  |  |  |  |  |  |  | 12-052 | 13-002 |  |  |  |  |  |  |  |  |  |  |
| 14264228M |  | Subway Steel Delivered | milestone | 0d | 2013-08-30 A | 2013-08-30 A | 14264008, 14264008a, 14264002M | 100% |  | 2013-09-03 | 2013-09-03 |  |  |  |  |  |  |  |  |  |  | 0 |  |  | ELOUADRHIRI L | 1 | 1 | M | LATIFA E |  |  |  | IN |  |  |  |  |  |  |  |  |  |  |  | 12-052 | 13-002 |  |  |  |  |  |  |  |  |  |  |
| 14264230 |  | Subway Level 1 addition wiring Power Dist. |  | 5d | 2013-08-30 A | 2013-08-30 A | 14264228M, 14264009 | 100% |  | 2013-09-03 | 2013-09-09 |  |  |  | PROCUREMENT<$50K 60 | 10,648.18 |  | 0 | 10648.1761 | 1064817.61 | 100 | 10648.1761 |  | 10648.1761 | ELOUADRHIRI L | 1 | 1 | H | LATIFA E |  |  |  | IN |  |  |  |  |  |  |  |  |  |  |  | 12-052 | 13-002 |  |  |  |  |  |  |  |  |  |  |
| 14264235 |  | Hall B Control Survey |  | 5d | 2013-08-30 A | 2013-08-30 A | 14264260, 14264228M, 14264009 | 100% |  | 2014-02-07 | 2014-02-13 |  |  |  | PROCUREMENT<$50K 60 | 10,648.18 |  | 0 | 10648.1761 | 1064817.61 | 100 | 10648.1761 |  | 10648.1761 | ELOUADRHIRI L | 1 | 1 | H | LATIFA E |  |  |  | IN |  |  |  |  |  |  |  |  |  |  |  | 12-052 | 13-002 |  |  |  |  |  |  |  |  |  |  |
| 14264238M |  | Start Mods of FWD Carriage | milestone | 0d | 2013-08-30 A | 2013-08-30 A | 14264002M | 100% |  | 2013-09-03 | 2013-09-03 |  |  |  |  |  |  |  |  |  |  | 0 |  |  | ELOUADRHIRI L | 1 | 1 | M | LATIFA E |  |  |  | IN |  |  |  |  |  |  |  |  |  |  | XX | 12-052 | 13-002 |  |  |  |  |  |  |  |  |  |  |
| 14264260 |  | Reinforce Fwd Carriage, add motion sysytem mounts and detector mounts |  | 44d | 2013-08-30 A | 2013-08-30 A | 14264002M, 14264013 FS-40d | 100% |  | 2013-11-26 | 2014-02-06 |  |  |  | MECH TECH [48 h]; SKLLD TRADE [24 h] | 3,126.24 | 3,029.76 |  |  |  |  | 3029.76 |  | 3029.76 | ELOUADRHIRI L | 1 | 1 | H | LATIFA E |  |  |  | IN |  |  |  |  |  |  |  |  |  |  |  | 12-052 | 13-002 |  |  |  |  |  |  |  |  |  |  |
| 14264265 |  | Add Hand rails and stairs to FC level 0 |  | 3d | 2013-08-30 A | 2013-08-30 A | 14264260 | 100% |  | 2014-02-07 | 2014-02-11 |  |  |  |  |  |  |  |  |  |  | 0 |  |  | ELOUADRHIRI L | 1 | 1 | Z | LATIFA E |  |  |  | IN |  |  |  |  |  |  |  |  |  |  |  | 12-052 | 13-002 |  |  |  |  |  |  |  |  |  |  |
| 14264267 |  | Add AC power to Level 0 FC |  | 3d | 2013-08-30 A | 2013-08-30 A | 14264265 | 100% |  | 2014-02-12 | 2014-02-14 |  |  |  |  |  |  |  |  |  |  | 0 |  |  | ELOUADRHIRI L | 1 | 1 | Z | LATIFA E |  |  |  | IN |  |  |  |  |  |  |  |  |  |  |  | 12-052 | 13-002 |  |  |  |  |  |  |  |  |  |  |
| 14264273 |  | Vend Fab Motion System |  | 34d | 2013-08-30 A | 2013-08-30 A | 14264271 | 100% |  | 2013-09-03 | 2013-10-18 |  |  |  | PROCUREMENT<$50K 60 | 5,763.62 |  | 0 | 5763.615536 | 576361.5536 | 100 | 5763.615536 |  | 5763.615536 | ELOUADRHIRI L | 1 | 1 | H | LATIFA E |  |  |  | IN |  |  |  |  |  |  |  |  |  |  |  | 12-052 | 13-002 |  |  |  |  |  |  |  |  |  |  |
| 14264280 |  | Modify LTCC gas piping |  | 15d | 2013-08-30 A | 2013-08-30 A | 14264267, 14264238M | 100% |  | 2014-02-18 | 2014-03-10 |  |  |  | MECH TECH [240 h] | 11,356.8 | 11,006.4 |  |  |  |  | 11006.4 |  | 11006.4 | ELOUADRHIRI L | 1 | 1 | H | LATIFA E |  |  |  | IN |  |  |  |  |  |  |  |  |  |  |  | 12-052 | 13-002 |  |  |  |  |  |  |  |  |  |  |
| 14264285 |  | Modify Lead nose |  | 4d | 2013-08-30 A | 2013-08-30 A | 14264278 | 100% |  | 2014-02-20 | 2014-02-25 |  |  |  | MECH TECH [64 h] | 3,028.48 | 2,935.04 |  |  |  |  | 2935.04 |  | 2935.04 | ELOUADRHIRI L | 1 | 1 | H | LATIFA E |  |  |  |  |  |  |  |  |  |  |  |  |  |  |  | 12-052 | 13-002 |  |  |  |  |  |  |  |  |  |  |
| 14264295 |  | Install panel 2 TOF brackets |  | 10d | 2013-08-30 A | 2013-08-30 A | 14264290 FS-1d | 100% |  | 2013-09-16 | 2013-09-27 |  |  |  | MECH TECH [40 h]; PLABOR | 18,923.08 | 1,834.4 |  |  |  |  | 18923.07676 |  | 18923.07676 | ELOUADRHIRI L | 1 | 1 | H | LATIFA E |  |  |  |  |  |  |  |  |  |  |  |  |  |  |  | 12-052 | 13-002 |  |  |  |  |  |  |  |  |  |  |
| 14264297M |  | Start Forward Carriage Precabling | milestone | 0d | 2013-08-30 A | 2013-08-30 A | 14264295 | 100% |  | 2013-09-30 | 2013-09-30 |  |  |  |  |  |  |  |  |  |  | 0 |  |  | ELOUADRHIRI L | 1 | 1 | M | LATIFA E |  |  |  | IN |  |  |  |  |  |  |  |  |  |  |  | 12-052 | 13-002 |  |  |  |  |  |  |  |  |  |  |
| 14264300 |  | Install 10 electronics racks level 0 |  | 3d | 2013-08-30 A | 2013-08-30 A | 14264297M | 100% |  | 2013-09-30 | 2013-10-02 |  |  |  | MECH TECH [80 h] | 3,746.67 | 3,668.8 |  |  |  |  | 3668.8 |  | 3668.8 | ELOUADRHIRI L | 1 | 1 | H | LATIFA E |  |  |  |  |  |  |  |  |  |  |  |  |  |  |  | 12-052 | 13-002 |  |  |  |  |  |  |  |  |  |  |
| 14264305 |  | Install 2 electronics racks level 2 |  | 2d | 2013-08-30 A | 2013-08-30 A | 14264300 | 100% |  | 2013-10-03 | 2013-10-04 |  |  |  | MECH TECH [10 h] | 473.2 | 458.6 |  |  |  |  | 458.6 |  | 458.6 | ELOUADRHIRI L | 1 | 1 | H | LATIFA E |  |  |  |  |  |  |  |  |  |  |  |  |  |  |  | 12-052 | 13-002 |  |  |  |  |  |  |  |  |  |  |
| 14264308 |  | Reroute EC, CC, TOF HV/signal cables |  | 52d | 2013-08-30 A | 2013-08-30 A | 14264300 FS-1d, 14264305 | 100% |  | 2013-10-07 | 2013-12-19 |  |  |  | MECH TECH [511.54 h] | 24,206.07 | 23,459.22 |  |  |  |  | 23459.2244 |  | 64204 | ELOUADRHIRI L | 1 | 1 | S | LATIFA E | 11 -035 |  |  |  |  |  |  |  |  |  |  |  |  | 12-007 |  | 12-052 | 13-002 | ST |  |  |  |  |  |  |  |  |  |
| 14264318 |  | Relocate PMT signals/HV/network patch panels |  | 5d | 2013-08-30 A | 2013-08-30 A | 14264300, 14264316 | 100% |  | 2013-10-03 | 2013-10-09 |  |  |  | ELEC TECH [80 h] | 3,759.2 | 3,643.2 |  |  |  |  | 3643.2 |  | 3643.2 | ELOUADRHIRI L | 1 | 1 | H | LATIFA E | 11 -035 |  |  |  |  |  |  |  |  |  |  |  |  |  |  | 12-052 | 13-002 |  |  |  |  |  |  |  |  |  |  |
| 14264328 |  | Relocate electronic crates |  | 30d | 2013-08-30 A | 2013-08-30 A | 14264002M, 14264318 | 100% |  | 2013-10-10 | 2013-11-20 |  |  |  | ELEC TECH [480 h] | 22,555.2 | 21,859.2 |  |  |  |  | 11658.24 |  | 21859.2 | ELOUADRHIRI L | 1 | 1 | H | LATIFA E |  |  |  |  |  |  |  |  |  |  |  |  |  |  |  | 12-052 | 13-002 |  |  |  |  |  |  |  |  |  |  |
| 14264340M |  | Start Beamline Modifications | milestone | 0d | 2013-08-30 A | 2013-08-30 A | 14264002M FS+15d | 100% |  | 2013-09-24 | 2013-09-24 |  |  |  |  |  |  |  |  |  |  | 0 |  |  | ELOUADRHIRI L | 1 | 1 | M | LATIFA E |  |  |  | IN |  |  |  |  |  |  |  |  |  |  |  | 12-052 | 13-002 |  |  |  |  |  |  |  |  |  |  |
| 14264345 |  | Install New Tagger Window |  | 3d | 2013-08-30 A | 2013-08-30 A | 14264228M, 14264009 | 100% |  | 2013-09-03 | 2013-09-05 |  |  |  | MECH TECH [72 h] | 3,301.92 | 3,301.92 |  |  |  |  | 3301.92 |  | 3301.92 | ELOUADRHIRI L | 1 | 1 | H | LATIFA E |  |  |  | IN |  |  |  |  |  |  |  |  |  |  |  | 12-052 | 13-002 |  |  |  |  |  |  |  |  |  |  |
| 14264350 |  | Move Moeller Quads and Table |  | 15d | 2013-08-30 A | 2013-08-30 A | 14264340M | 100% |  | 2013-09-24 | 2013-10-14 |  |  |  | MECH TECH [240 h] | 11,240 | 11,006.4 |  |  |  |  | 11006.4 |  | 11006.4 | ELOUADRHIRI L | 1 | 1 | H | LATIFA E |  |  |  | IN |  |  |  |  |  |  |  |  |  |  |  | 12-052 | 13-002 |  |  |  |  |  |  |  |  |  |  |
| 14264355 |  | Move GONI |  | 7d | 2013-08-30 A | 2013-08-30 A | 14264350 | 100% |  | 2013-10-15 | 2013-10-23 |  |  |  | MECH TECH [80 h] | 3,785.6 | 3,668.8 |  |  |  |  | 3668.8 |  | 3668.8 | ELOUADRHIRI L | 1 | 1 | H | LATIFA E |  |  |  |  |  |  |  |  |  |  |  |  |  |  |  | 12-052 | 13-002 |  |  |  |  |  |  |  |  |  |  |
| 14264360 |  | Align Goni and Moeller Quads |  | 3d | 2013-08-30 A | 2013-08-30 A | 14264355 | 100% |  | 2013-10-24 | 2013-10-28 |  |  |  | MECH TECH [24 h] | 1,135.68 | 1,100.64 |  |  |  |  | 1100.64 |  | 1100.64 | ELOUADRHIRI L | 1 | 1 | H | LATIFA E |  |  |  |  |  |  |  |  |  |  |  |  |  |  |  | 12-052 | 13-002 |  |  |  |  |  |  |  |  |  |  |
| 14264364M |  | Start Installation of FWD Detectors | milestone | 0d | 2013-08-30 A | 2013-08-30 A | 14264260, 14264362 | 100% |  | 2014-02-07 | 2014-02-07 |  |  |  |  |  |  |  |  |  |  | 0 |  |  | ELOUADRHIRI L | 1 | 1 | M | LATIFA E | 11 -035 | 12-027 |  |  |  |  | 09-030 | 09-030 | 11-026 |  |  |  |  |  |  | 12-052 | 13-002 |  | 11-022 |  |  |  |  |  |  |  |  |
| 14264365 |  | Transport and install first 5 sectors PCAL |  | 15d | 2013-08-30 A | 2013-08-30 A | 14264220M, 14264362, 14264364M | 100% |  | 2014-02-07 | 2014-02-28 |  |  |  | PLABOR; MECH TECH [400 h] | 29,576.18 | 18,344 |  |  |  |  | 28992.1761 |  | 28992.1761 | ELOUADRHIRI L | 1 | 1 | H | LATIFA E |  |  |  |  |  |  |  |  |  |  |  |  |  |  |  | 12-052 | 13-002 |  |  |  |  |  |  |  |  |  |  |
| 14264370 |  | Check PCAL positions |  | 3d | 2013-08-30 A | 2013-08-30 A | 14264365 | 100% |  | 2014-03-03 | 2014-03-05 |  |  |  | MECH TECH [40 h] | 1,892.8 | 1,834.4 |  |  |  |  | 1834.4 |  | 1834.4 | ELOUADRHIRI L | 1 | 1 | H | LATIFA E |  |  |  |  |  |  |  |  |  |  |  |  |  |  |  | 12-052 | 13-002 |  |  |  |  |  |  |  |  |  |  |
| 14264375 |  | Cable/test/repair Preshower calorimeters |  | 9d | 2013-08-30 A | 2013-08-30 A | 14264365 FS-12d | 100% |  | 2014-02-12 | 2014-02-25 |  |  |  | MECH TECH [40 h] | 1,892.8 | 1,834.4 |  |  |  |  | 1834.4 |  | 1834.4 | ELOUADRHIRI L | 1 | 1 | H | LATIFA E |  |  |  |  |  |  |  |  |  |  |  |  |  |  |  | 12-052 | 13-002 |  |  |  |  |  |  |  |  |  |  |
| 14264400 |  | Transport and Install ToF 1a - First 3 sectors |  | 6d | 2013-08-30 A | 2013-08-30 A | 14264370, 14264206M | 100% |  | 2014-03-06 | 2014-03-13 |  |  |  | MECH TECH [112 h]; PLABOR | 8,707.26 | 5,136.32 |  |  |  |  | 8543.736352 |  | 8543.736352 | ELOUADRHIRI L | 1 | 1 | H | LATIFA E |  |  |  |  |  |  |  |  |  |  |  |  |  |  |  | 12-052 | 13-002 |  |  |  |  |  |  |  |  |  |  |
| 14264405 |  | Survey (as found location) TOF 1a positions |  | 1d | 2013-08-30 A | 2013-08-30 A | 14264400 | 100% |  | 2014-03-14 | 2014-03-14 |  |  |  | MECH TECH [24 h] | 1,135.68 | 1,100.64 |  |  |  |  | 1100.64 |  | 1100.64 | ELOUADRHIRI L | 1 | 1 | H | LATIFA E |  |  |  |  |  |  |  |  |  |  |  |  |  |  |  | 12-052 | 13-002 |  |  |  |  |  |  |  |  |  |  |
| 14264410 |  | Cable/test/repair 1a's TOF's |  | 4d | 2013-08-30 A | 2013-08-30 A | 14264400 FS-4d, 14264405 | 100% |  | 2014-03-17 | 2014-03-20 |  |  |  | ELEC TECH [24 h] | 1,127.76 | 1,092.96 |  |  |  |  | 1092.96 |  | 1092.96 | ELOUADRHIRI L | 1 | 1 | H | LATIFA E |  |  |  |  |  |  |  |  |  |  |  |  |  |  |  | 12-052 | 13-002 |  |  |  |  |  |  |  |  |  |  |
| 14264545 |  | Install and wire up Torus PS (G0) |  | 5d | 2013-08-30 A | 2013-08-30 A | 14264002M FS+40d | 100% |  | 2013-10-29 | 2013-11-04 |  |  |  |  |  |  |  |  |  |  | 0 |  |  | ELOUADRHIRI L | 1 | 1 | H | LATIFA E |  |  |  |  |  |  |  |  |  |  |  |  |  |  |  | 12-052 | 13-002 |  |  |  |  |  |  |  |  |  |  |
| 14264882 |  | Install DC signal cable trays and gas lines |  | 10d | 2013-08-30 A | 2013-08-30 A | 14264002M | 100% |  | 2013-09-03 | 2013-09-16 |  |  |  | PROCUREMENT<$50K 60; PLABOR; MECH TECH [160 h] | 30,826.69 | 7,337.6 | 0 | 4535.344966 | 453534.4966 | 100 | 30826.698424 |  | 30826.698424 | ELOUADRHIRI L | 1 | 1 | H | LATIFA E | 11 -035 |  |  | IN |  |  | 09-030 | 09-030 | 11-026 |  |  |  |  |  | XX | 12-052 | 13-002 |  |  | 12-024 |  |  |  |  |  |  |  |
| 14264884 |  | Route DC Signal Cables |  | 20d | 2013-08-30 A | 2013-08-30 A | 14264882 | 100% |  | 2013-09-17 | 2013-10-14 |  |  |  | PROCUREMENT<$50K 60; PLABOR; MECH TECH [320 h] | 57,245.17 | 14,675.2 | 0 | 4535.344966 | 453534.4966 | 100 | 57011.570121 |  | 57011.570121 | ELOUADRHIRI L | 1 | 1 | S | LATIFA E | 11 -035 |  |  | IN |  |  | 09-030 | 09-030 | 11-026 |  |  |  |  |  |  | 12-052 | 13-002 | ST |  | 12-024 |  |  |  |  |  |  |  |
| 14264886 |  | Install DC HV/LV Racks and cable trays |  | 6d | 2013-08-30 A | 2013-08-30 A | 14264884 FS-1d | 100% |  | 2013-10-14 | 2013-10-21 |  |  |  | MECH TECH [95.66 h]; PROCUREMENT<$50K 60; PLABOR | 20,775.12 | 4,386.97 | 0 | 4535.344966 | 453534.4966 | 100 | 20635.461061 |  | 20635.461061 | ELOUADRHIRI L | 1 | 1 | H | LATIFA E | 11 -035 |  |  | IN |  |  | 09-030 | 09-030 | 11-026 |  |  |  |  |  |  | 12-052 | 13-002 |  |  | 12-024 |  |  |  |  |  |  |  |
| 14264998 |  | Re-Baseline Actuals Adjustment |  | 1d | 2013-08-30 A | 2013-08-30 A |  | 100% |  | 2013-09-03 | 2013-09-03 |  |  |  | PROCUREMENT>$50K 69 NO ESCALATION | -190,953.08 |  |  |  |  | 100 |  | ADJ |  |  |  |  |  |  |  |  |  |  |  |  |  |  |  |  |  |  |  |  |  |  |  |  |  |  |  |  |  |  |  |  |  |
| 24264002LOE |  | Installation Procurement Support FY13 |  | 20d | 2013-09-03 A | 2013-09-30 A | 9-130M FS+228d | 100% |  | 2013-10-01 | 2013-10-28 |  |  | 8/5 M-F w/JLAB Holidays ReBaseline | MECH ENG [137.58 h] | 10,273.1 | 9,955.29 |  |  |  |  | 0 |  |  | ELOUADRHIRI L | 1 | 1 | E | LATIFA E | 11 -035 |  |  |  |  |  | 09-030 | 09-030 | 11-026 |  |  | 100 | 100 |  |  |  |  |  |  |  | 24264002LOE | 9955.2888 | PE | 13-015 | PR |  |  |
| 24264140 |  | PCAL - Procure PCAL installation stand |  | 40d | 2013-09-03 A | 2014-01-09 | 9-130M FS+228d |  | 40d | 2013-10-01 | 2013-11-25 | 403d | 0d | 8/5 M-F w/JLAB Holidays ReBaseline | PROCUREMENT<$50K 60 NO ESCALATION FY14 | 21,969 |  | 21969 | 0 | 0 | 100 | 0 |  |  | ELOUADRHIRI L | 1 | 1 | D | LATIFA E |  |  |  | IN |  |  |  |  |  |  |  |  |  |  |  | 12-052 | 13-002 |  |  |  | 24264140 |  |  | 13-015 | PR | PE | OB-2 |
| 24264278 |  | Install Fwd Carriage Mods |  | 20d | 2013-09-03 A | 2013-09-23 A | 9-130M FS+228d | 100% |  | 2013-10-01 | 2013-10-28 |  |  | 8/5 M-F w/JLAB Holidays ReBaseline | PROCUREMENT<$50K 60 | 71,953 |  | 0 | 71953 | 7195300 | 100 | 0 |  |  | ELOUADRHIRI L | 1 | 1 | H | LATIFA E |  |  |  | IN |  |  |  |  |  |  |  |  |  |  |  | 12-052 | 13-002 |  |  |  | 24264278 | 71953 |  | 13-015 | PR | PE | OB |

Notes:
- 14264308: Steps: Reroute EC, CC, TOF HV/signal cables (done)
- 14264884: Steps: Route DC Signal Cables (done)

| ID | Activity | Type | Duration | Start | Finish | Predecessors | Complete | Remaining | Planned start | Planned finish | Total float | Free float | Calendar | Resources | Cost | Actual cost | Original Activity ID Rebaseline | Remaining Material Cost Based on % Compl | Claimed Material Cost Based on % Complet | Initial Claimed Material Calc | Claimed Material Divider | MONTHLY EV COST | PRIOR MONTH EV COST | PHAS - Project Phase | RESP - Responsibility | STRT%COMP for CM EVM | FNSH%COMP for CM EVM | EVMS Reporting Codes | CAM RESPONSIBLE | CR 09-030 | CR 09-030 Repair | CR 11-026 | CR 11-035 | CR 12-052 | CR 13-002 | BOE Procurement | CR 13-015 | Post Rebaseline | Obligated Prior to Rebaseline | Activities with Steps | BOE Labor | CR 14-001 | CR 13-010 | LOE % Pre Calc | LOE % | LOE Divider | LOE Multiplier | Advance Purchase Plan > 500K | CR 08-016 | 12 GEV MAJOR PROCUREMENT CATAGORY | CR 09-012 | CR 12-027 | BOE Expenses | CR 12-024 | CR 11-022 |
| --- | --- | --- | --- | --- | --- | --- | --- | --- | --- | --- | --- | --- | --- | --- | --- | --- | --- | --- | --- | --- | --- | --- | --- | --- | --- | --- | --- | --- | --- | --- | --- | --- | --- | --- | --- | --- | --- | --- | --- | --- | --- | --- | --- | --- | --- | --- | --- | --- | --- | --- | --- | --- | --- | --- | --- |
| 24264362 | Vend Fab Fwd. Detector Installation Tooling |  | 40d | 2013-09-03 A | 2013-09-23 A | 9-130M FS+228d | 100% |  | 2013-10-01 | 2013-11-25 |  |  | 8/5 M-F w/JLAB Holidays ReBaseline | PROCUREMENT<$50K 60 NO ESCALATION FY14 | 21,069 |  | 24264362 | 0 | 21069 | 2106900 | 100 | 0 | 21069 | IN | ELOUADRHIRI L | 1 | 1 | D | LATIFA E | 09-030 | 09-030 | 11-026 | 11 -035 | 12-052 | 13-002 | PE | 13-015 | PR | OB-2 |  |  |  |  |  |  |  |  |  |  |  |  |  |  |  |  |
| 24264395 | Cable/test/repair EC |  | 85d | 2013-09-09 A | 2014-04-11 | 9-140M, 24264365 FS-142d | 55% | 105d | 2013-10-29 | 2014-03-11 | 423d | 516d | 8/5 M-F w/JLAB Holidays ReBaseline | SCIENTIST [96 h]; MECH TECH [192 h] | 16,302.72 | 2,089.21 | 24264395 |  |  |  |  | 0 | 8966.496 |  | ELOUADRHIRI L | 1 | 1 | S | LATIFA E |  |  |  |  | 12-052 | 13-002 |  | 13-015 | PR |  | ST | PE | 14-001 |  |  |  |  |  |  |  |  |  |  |  |  |  |
| 24264035M | ToF Panel 1a - First 3 units Ready for Installation | milestone | 0d | 2013-09-16 A | 2013-09-16 A | 9-130M FS+228d | 100% |  | 2013-10-01 | 2013-10-01 |  |  | 8/5 M-F w/JLAB Holidays ReBaseline |  |  |  | 24264035M |  |  |  |  | 0 |  |  | ELOUADRHIRI L | 1 | 1 | M | LATIFA E |  |  |  |  | 12-052 | 13-002 |  | 13-015 | PR |  |  |  |  |  |  |  |  |  |  |  |  |  |  |  |  |  |
| 24264045M | ToF Panel 2 Ready for Installation | milestone | 0d | 2013-09-16 A | 2013-09-16 A | 9-130M FS+228d | 100% |  | 2013-10-01 | 2013-10-01 |  |  | 8/5 M-F w/JLAB Holidays ReBaseline |  |  |  | 24264045M |  |  |  |  | 0 |  |  | ELOUADRHIRI L | 1 | 1 | M | LATIFA E |  |  |  |  | 12-052 | 13-002 |  | 13-015 | PR |  |  |  |  | 13-010 |  |  |  |  |  |  |  |  |  |  |  |  |
| 24264300 | Precable forward carriage FY13 |  | 5d | 2013-09-16 A | 2014-02-05 | 24264297M | 16% | 58d | 2013-10-22 | 2013-10-28 | 385d | 0d | 8/5 M-F w/JLAB Holidays ReBaseline | ELEC TECH [89.53 h] | 4,207.01 | 1,539.24 | 24264300 |  |  |  |  | 0 | 652.351392 |  | ELOUADRHIRI L | 1 | 1 | S | LATIFA E |  |  |  |  | 12-052 | 13-002 |  | 13-015 | PR |  | ST | PE |  |  |  |  |  |  |  |  |  |  |  |  |  |  |
| 24264300a | Precable forward carriage FY14 |  | 81d | 2013-09-16 A | 2014-02-05 | 24264300 FS-100d | 16% | 58d | 2013-10-01 | 2014-02-05 | 385d | 0d | 8/5 M-F w/JLAB Holidays ReBaseline | ELEC TECH [1450.47 h] | 68,157.59 | 24,937.21 | 24264300 |  |  |  |  | 0 | 10905.213648 |  | ELOUADRHIRI L | 1 | 1 | S | LATIFA E |  |  |  |  | 12-052 | 13-002 |  | 13-015 | PR |  | ST | PE | 14-001 |  |  |  |  |  |  |  |  |  |  |  |  |  |
| 24264297M | Start Forward Carriage Precabling | milestone | 0d | 2013-09-22 A | 2013-09-22 A | 24264278 FS-5d | 100% |  | 2013-10-22 | 2013-10-22 |  |  | 8/5 M-F w/JLAB Holidays ReBaseline |  |  |  | 24264297M |  |  |  |  | 0 |  | IN | ELOUADRHIRI L | 1 | 1 | M | LATIFA E |  |  |  |  | 12-052 | 13-002 |  | 13-015 | PR |  |  |  |  |  |  |  |  |  |  |  |  |  |  |  |  |  |
| 24264003LOE | Installation Enginering Support FY14 |  | 247d | 2013-10-01 A | 2014-09-30 | 24264002LOE | 9% | 224d | 2013-11-01 | 2014-10-31 | 742d | 897d | 8/5 M-F w/JLAB Holidays ReBaseline | MECH ENG [1706 h] | 127,387.02 | 11,861.95 | 24264003LOE |  |  |  |  | 11859.731562 |  |  | ELOUADRHIRI L | 1 | 1 | E | LATIFA E | 09-030 | 09-030 | 11-026 | 11 -035 |  |  |  | 13-015 | PR |  |  | PE | 14-001 |  | 90.6882591 | 9.31174089 | 100 | 100 |  |  |  |  |  |  |  |  |
| 24264050M | ToF Panel 1b - First 3 units Ready for Installation | milestone | 0d | 2013-10-21 A | 2013-10-21 A | 242232320R, 242232320S | 100% |  | 2014-04-01 | 2014-04-01 |  |  | 8/5 M-F w/JLAB Holidays ReBaseline |  |  |  | 24264050M |  |  |  |  | 0 |  |  | ELOUADRHIRI L | 1 | 1 | M | LATIFA E |  |  |  |  | 12-052 | 13-002 |  | 13-015 | PR |  |  |  |  |  |  |  |  |  |  |  |  |  |  |  |  |  |
| 24264055M | ToF Panel 1b - Last 3 units Ready for Installation | milestone | 0d | 2013-10-21 A | 2013-10-21 A | 242232320S, 242232320R | 100% |  | 2014-04-01 | 2014-04-01 |  |  | 8/5 M-F w/JLAB Holidays ReBaseline |  |  |  | 24264055M |  |  |  |  | 0 |  |  | ELOUADRHIRI L | 1 | 1 | M | LATIFA E |  |  |  |  | 12-052 | 13-002 |  | 13-015 | PR |  |  |  |  |  |  |  |  |  |  |  |  |  |  |  |  |  |
| 24264025M | R2 Drift Chambers Ready for Installation | milestone | 0d | 2013-11-01 | 2013-11-01 | 9-130M FS+228d |  |  |  |  | 487d | 462d | 8/5 M-F w/JLAB Holidays ReBaseline |  |  |  | 24264025M |  |  |  |  | 0 |  |  | ELOUADRHIRI L | 1 | 1 | M | LATIFA E |  |  |  |  | 12-052 | 13-002 |  | 13-015 | PR |  |  |  |  |  |  |  |  |  |  |  |  |  |  |  |  |  |
| 24264515 | Mods to CRYO transfer lines |  | 40d | 2013-11-01 | 2014-01-09 | 9-140M |  |  |  |  | 316d | 186d | 8/5 M-F w/JLAB Holidays ReBaseline | MECH TECH [320 h] | 15,142.4 |  | 24264515 |  |  |  |  | 0 |  | IN | ELOUADRHIRI L | 1 | 1 | S | LATIFA E |  |  |  |  | 12-052 | 13-002 |  | 13-015 | PR |  |  | PE | 14-001 |  |  |  |  |  |  |  |  |  |  |  |  |  |
| 24264270 | Add AC power to Level 0 FC |  | 20d | 2013-11-15 | 2013-12-16 | 9-130M FS+228d, 9-140M FS+33d |  |  |  |  | 425d | 0d | 8/5 M-F w/JLAB Holidays ReBaseline |  |  |  | 24264270 |  |  |  |  | 0 |  | IN | ELOUADRHIRI L | 1 | 1 | Z | LATIFA E |  |  |  |  | 12-052 | 13-002 |  | 13-015 | PR |  |  |  |  |  |  |  |  |  |  |  |  |  |  |  |  |  |
| 24264935 | Widen the corners of the Hall access walls to allow R3 to pass through horizontal |  | 83d | 2013-11-15 | 2014-03-26 | 9-140M FS+33d |  |  |  |  | 394d | 369d | 8/5 M-F w/JLAB Holidays ReBaseline | PROCUREMENT<$50K 60 | 8,255.2 |  | 24264935 | 8255.2 | 0 | 0 | 100 | 0 |  | IN | ELOUADRHIRI L | 1 | 1 | H | LATIFA E |  | 09-030 | 11-026 | 11 -035 | 12-052 | 13-002 | EJ | 13-015 | PR |  |  |  | 14-001 |  |  |  |  |  | APP | 08-016 | 4211 | 09-012 | 12-027 |  |  |  |
| 24264890 | DC - design mounts and adjusters for DC to Torus |  | 82d | 2013-12-05 | 2014-04-10 | 9-140M FS+45d |  |  |  |  | 226d | 0d | 8/5 M-F w/JLAB Holidays ReBaseline | PLABOR | 25,756.22 |  | 24264890 |  |  |  |  | 0 |  | IN | ELOUADRHIRI L | 1 | 1 | S | LATIFA E |  | 09-030 | 11-026 | 11 -035 | 12-052 | 13-002 |  | 13-015 | PR |  | ST |  | 14-001 |  |  |  |  |  | APP | 08-016 | 4211 | 09-012 | 12-027 | PE |  |  |
| 24264020M | R3 Drift Chambers Ready for Installation | milestone | 0d | 2013-12-16 | 2013-12-16 | 242213355M FS-315d |  |  |  |  | 480d | 455d | 8/5 M-F w/JLAB Holidays ReBaseline |  |  |  | 24264020M |  |  |  |  | 0 |  |  | ELOUADRHIRI L | 1 | 1 | M | LATIFA E |  |  |  |  | 12-052 | 13-002 |  | 13-015 | PR |  |  |  |  |  |  |  |  |  |  |  |  |  |  |  |  |  |
| 24264888 | Reroute DC gas lines to the distribution pannel |  | 134d | 2014-01-02 | 2014-07-11 | 9-140M FS+59d |  |  |  |  | 360d | 453d | 8/5 M-F w/JLAB Holidays ReBaseline | MECH TECH [240 h] | 11,356.8 |  | 24264888 |  |  |  |  | 0 |  | IN | ELOUADRHIRI L | 1 | 1 | S | LATIFA E | 09-030 | 09-030 | 11-026 | 11 -035 | 12-052 | 13-002 |  | 13-015 | PR |  | ST | PE | 14-001 |  |  |  |  |  |  |  |  |  |  |  | 12-024 |  |
| 24264364M | Start Installation of FWD Detectors | milestone | 0d | 2014-01-10 | 2014-01-10 | 24264278, 24264140, 24264362 |  |  |  |  | 403d | 18d | 8/5 M-F w/JLAB Holidays ReBaseline |  |  |  | 24264364M |  |  |  |  | 0 |  |  | ELOUADRHIRI L | 1 | 1 | M | LATIFA E | 09-030 | 09-030 | 11-026 | 11 -035 | 12-052 | 13-002 |  | 13-015 | PR |  |  |  |  |  |  |  |  |  |  |  |  |  | 12-027 |  |  | 11-022 |
| 24264895 | DC - mounts and adjusters Engineering Analysis |  | 37d | 2014-01-16 | 2014-03-10 | 24264890 FS-60d |  |  |  |  | 249d | 58d | 8/5 M-F w/JLAB Holidays ReBaseline | MECH ENG [240 h] | 17,920.8 |  | 24264895 |  |  |  |  | 0 |  | IN | ELOUADRHIRI L | 1 | 1 | S | LATIFA E |  | 09-030 | 11-026 | 11 -035 | 12-052 | 13-002 |  | 13-015 | PR |  | ST | PE | 14-001 |  |  |  |  |  | APP | 08-016 | 4211 | 09-012 | 12-027 |  |  |  |
| 24264517 | Modify Space Frame For Cryo Can |  | 42d | 2014-02-03 | 2014-04-01 | 9-130M FS+232d, 9-140M FS+80d |  |  |  |  | 240d | 0d | 8/5 M-F w/JLAB Holidays ReBaseline | PROCUREMENT<$50K 60 NO ESCALATION FY14 | 20,000 |  | 24264517 | 20000 | 0 | 0 | 100 | 0 |  |  | ELOUADRHIRI L | 1 | 1 | D | LATIFA E |  |  |  |  | 12-052 | 13-002 | PE | 13-015 | PR |  |  |  |  |  |  |  |  |  |  |  |  |  |  |  |  |  |
| 24264365 | Transport and install PCAL |  | 15d | 2014-02-06 | 2014-02-26 | 24264300, 24264362, 24264140, 24264364M, 242223563M, 24264300a |  |  |  |  | 385d | 0d | 8/5 M-F w/JLAB Holidays ReBaseline | MECH TECH [480 h] | 22,713.6 |  | 24264365 |  |  |  |  | 0 |  |  | ELOUADRHIRI L | 1 | 1 | S | LATIFA E |  |  |  |  | 12-052 | 13-002 |  | 13-015 | PR |  | ST | PE | 14-001 |  |  |  |  |  |  |  |  |  |  |  |  |  |
| 24264280 | Modify LTCC gas piping |  | 43d | 2014-02-07 | 2014-04-08 | 24264270 FS+29d |  |  |  |  | 425d | 0d | 8/5 M-F w/JLAB Holidays ReBaseline | MECH DES [240 h]; MECH TECH [480 h] | 35,025.6 |  | 24264280 |  |  |  |  | 0 |  | IN | ELOUADRHIRI L | 1 | 1 | S | LATIFA E |  |  |  |  | 12-052 | 13-002 |  | 13-015 | PR |  | ST | PE | 14-001 |  |  |  |  |  |  |  |  |  |  |  |  |  |
| 24264390 | Cable/test/repair Preshower calorimeters |  | 20d | 2014-02-10 | 2014-03-07 | 24264365 FS-13d |  |  |  |  | 448d | 541d | 8/5 M-F w/JLAB Holidays ReBaseline | SCIENTIST [72 h]; MECH TECH [72 h] | 8,820 |  | 24264390 |  |  |  |  | 0 |  |  | ELOUADRHIRI L | 1 | 1 | H | LATIFA E |  |  |  |  | 12-052 | 13-002 |  | 13-015 | PR |  |  | PE | 14-001 |  |  |  |  |  |  |  |  |  |  |  |  |  |
| 24264370 | Check PCAL positions |  | 2d | 2014-02-27 | 2014-02-28 | 24264365 |  |  |  |  | 442d | 0d | 8/5 M-F w/JLAB Holidays ReBaseline | MECH TECH [48 h] | 2,271.36 |  | 24264370 |  |  |  |  | 0 |  |  | ELOUADRHIRI L | 1 | 1 | H | LATIFA E |  |  |  |  | 12-052 | 13-002 |  | 13-015 | PR |  |  | PE | 14-001 |  |  |  |  |  |  |  |  |  |  |  |  |  |
| 24264400 | Transport and Install ToF 1a |  | 11d | 2014-03-04 | 2014-03-18 | 24264035M, 24264370 FS+1d |  |  |  |  | 442d | 0d | 8/5 M-F w/JLAB Holidays ReBaseline | MECH TECH [384 h] | 18,170.88 |  | 24264400 |  |  |  |  | 0 |  |  | ELOUADRHIRI L | 1 | 1 | S | LATIFA E |  |  |  |  | 12-052 | 13-002 |  | 13-015 | PR |  | ST | PE | 14-001 |  |  |  |  |  |  |  |  |  |  |  |  |  |
| 24264790 | Solenoid - design adjustment system for solenoid and HTCC rails |  | 25d | 2014-03-04 | 2014-04-07 | 9-140M FS+100d |  |  |  |  | 178d | 0d | 8/5 M-F w/JLAB Holidays ReBaseline | MECH DES [200 h] | 10,260 |  | 24264790 |  |  |  |  | 0 |  | IN | ELOUADRHIRI L | 1 | 1 | H | LATIFA E | 09-030 | 09-030 | 11-026 | 11 -035 | 12-052 | 13-002 |  | 13-015 | PR |  |  | PE | 14-001 |  |  |  |  |  |  |  |  |  |  |  |  |  |
| 24264410 | Cable/test/repair 1a's TOF's |  | 9d | 2014-03-05 | 2014-03-17 | 24264400 FS-10d, 24264405 FS-13d |  |  |  |  | 442d | 535d | 8/5 M-F w/JLAB Holidays ReBaseline | MECH TECH [144 h]; SCIENTIST [72 h] | 12,227.04 |  | 24264410 |  |  |  |  | 0 |  |  | ELOUADRHIRI L | 1 | 1 | S | LATIFA E |  |  |  |  | 12-052 | 13-002 |  | 13-015 | PR |  | ST | PE | 14-001 |  |  |  |  |  |  |  |  |  |  |  |  |  |
| 24264405 | Survey (as found location) TOF 1a positions |  | 2d | 2014-03-20 | 2014-03-21 | 24264400 FS+1d |  |  |  |  | 442d | 0d | 8/5 M-F w/JLAB Holidays ReBaseline | MECH TECH [72 h] | 3,407.04 |  | 24264405 |  |  |  |  | 0 |  |  | ELOUADRHIRI L | 1 | 1 | H | LATIFA E |  |  |  |  | 12-052 | 13-002 |  | 13-015 | PR |  |  | PE | 14-001 |  |  |  |  |  |  |  |  |  |  |  |  |  |
| 24264281 | Install new gas lines from gas sched to the hall |  | 10d | 2014-03-27 | 2014-04-09 | 24264280 FS-9d |  |  |  |  | 425d | 518d | 8/5 M-F w/JLAB Holidays ReBaseline | MECH TECH [280 h] | 13,249.6 |  | 24264281 |  |  |  |  | 0 |  | IN | ELOUADRHIRI L | 1 | 1 | S | LATIFA E |  |  |  |  | 12-052 | 13-002 |  | 13-015 | PR |  | ST | PE | 14-001 |  |  |  |  |  |  |  |  |  |  |  |  |  |
| 24264105 | SVT - Design mounts for SVT to solenoid cart |  | 39d | 2014-04-01 | 2014-05-23 | 9-140M FS+120d |  |  |  |  | 253d | 0d | 8/5 M-F w/JLAB Holidays ReBaseline | MECH DES [160 h] | 8,208 |  | 24264105 |  |  |  |  | 0 |  | IN | ELOUADRHIRI L | 1 | 1 | H | LATIFA E |  |  |  |  | 12-052 | 13-002 |  | 13-015 | PR |  |  | PE | 14-001 |  |  |  |  |  |  |  |  |  |  |  |  |  |
| 24264520 | Modify Space Frame Level 3 deck For Torus Cryo |  | 20d | 2014-04-02 | 2014-04-29 | 24264517 |  |  |  |  | 240d | 110d | 8/5 M-F w/JLAB Holidays ReBaseline | MECH TECH [80 h] | 3,785.6 |  | 24264520 |  |  |  |  | 0 |  |  | ELOUADRHIRI L | 1 | 1 | H | LATIFA E |  |  |  |  | 12-052 | 13-002 |  | 13-015 | PR |  |  | PE | 14-001 |  |  |  |  |  |  |  |  |  |  |  |  |  |
| 24264793 | Solenoid - design motion system |  | 24d | 2014-04-08 | 2014-05-09 | 24264790 |  |  |  |  | 214d | 0d | 8/5 M-F w/JLAB Holidays ReBaseline | MECH DES [200 h] | 10,260 |  | 24264793 |  |  |  |  | 0 |  | IN | ELOUADRHIRI L | 1 | 1 | H | LATIFA E | 09-030 | 09-030 | 11-026 | 11 -035 | 12-052 | 13-002 |  | 13-015 | PR |  |  | PE | 14-001 |  |  |  |  |  |  |  |  |  |  |  |  |  |
| 24264795 | Solenoid - design cart |  | 24d | 2014-04-08 | 2014-05-09 | 24264790 |  |  |  |  | 178d | 0d | 8/5 M-F w/JLAB Holidays ReBaseline | PLABOR | 12,878.11 |  | 24264795 |  |  |  |  | 0 |  | IN | ELOUADRHIRI L | 1 | 1 | S | LATIFA E | 09-030 | 09-030 | 11-026 | 11 -035 | 12-052 | 13-002 |  | 13-015 | PR |  | ST |  | 14-001 |  |  |  |  |  |  |  |  |  |  | PE |  |  |
| 24264905 | DC - design cable trays and gas system mounts |  | 127d | 2014-04-10 | 2014-10-08 | 9-140M FS+127d |  |  |  |  | 50d | 0d | 8/5 M-F w/JLAB Holidays ReBaseline | PLABOR | 30,048.93 |  | 24264905 |  |  |  |  | 0 |  | IN | ELOUADRHIRI L | 1 | 1 | S | LATIFA E |  | 09-030 | 11-026 | 11 -035 | 12-052 | 13-002 |  | 13-015 | PR |  | ST |  | 14-001 |  |  |  |  |  | APP | 08-016 | 4211 | 09-012 | 12-027 | PE |  |  |
| 24264430 | Transport and install ToF 1b |  | 12d | 2014-04-14 | 2014-04-29 | 24264365 FS+32d, 24264050M |  |  |  |  | 385d | 0d | 8/5 M-F w/JLAB Holidays ReBaseline | MECH TECH [384 h] | 18,170.88 |  | 24264430 |  |  |  |  | 0 |  |  | ELOUADRHIRI L | 1 | 1 | S | LATIFA E |  |  |  |  | 12-052 | 13-002 |  | 13-015 | PR |  | ST | PE | 14-001 |  |  |  |  |  |  |  |  |  |  |  |  |  |
| 24264796 | Solenoid - cart Engineering Analysis |  | 22d | 2014-04-28 | 2014-05-28 | 24264795 FS-10d |  |  |  |  | 178d | 2d | 8/5 M-F w/JLAB Holidays ReBaseline | MECH ENG [160 h] | 11,947.2 |  | 24264796 |  |  |  |  | 0 |  | IN | ELOUADRHIRI L | 1 | 1 | S | LATIFA E | 09-030 | 09-030 | 11-026 | 11 -035 | 12-052 | 13-002 |  | 13-015 | PR |  | ST | PE | 14-001 |  |  |  |  |  |  |  |  |  |  |  |  |  |
| 24264435 | Survey (as found location) TOF 1b's |  | 2d | 2014-04-30 | 2014-05-01 | 24264430 |  |  |  |  | 385d | 253d | 8/5 M-F w/JLAB Holidays ReBaseline | MECH TECH [72 h] | 3,407.04 |  | 24264435 |  |  |  |  | 0 |  |  | ELOUADRHIRI L | 1 | 1 | H | LATIFA E |  |  |  |  | 12-052 | 13-002 |  | 13-015 | PR |  |  | PE | 14-001 |  |  |  |  |  |  |  |  |  |  |  |  |  |
| 24264440 | Cable/test/repair 1b's TOF's |  | 10d | 2014-04-30 | 2014-05-13 | 24264430 |  |  |  |  | 401d | 494d | 8/5 M-F w/JLAB Holidays ReBaseline | MECH TECH [144 h]; SCIENTIST [72 h] | 12,227.04 |  | 24264440 |  |  |  |  | 0 |  |  | ELOUADRHIRI L | 1 | 1 | S | LATIFA E |  |  |  |  | 12-052 | 13-002 |  | 13-015 | PR |  | ST | PE | 14-001 |  |  |  |  |  |  |  |  |  |  |  |  |  |
| 24264030M | R1 Drift Chambers Ready for Installation | milestone | 0d | 2014-05-01 | 2014-05-01 | 242213100 |  |  |  |  | 384d | 359d | 8/5 M-F w/JLAB Holidays ReBaseline |  |  |  | 24264030M |  |  |  |  | 0 |  |  | ELOUADRHIRI L | 1 | 1 | M | LATIFA E |  |  |  |  | 12-052 | 13-002 |  | 13-015 | PR |  |  |  |  |  |  |  |  |  |  |  |  |  |  |  |  |  |
| 24264791 | Solenoid - procure rails and adjustment components for solenoid and HTCC rails |  | 63d | 2014-05-05 | 2014-08-01 | 24264790 FS+19d |  |  |  |  | 178d | 0d | 8/5 M-F w/JLAB Holidays ReBaseline | PROCUREMENT<$50K 60 | 22,783.32 |  | 24264791 | 22783.32 | 0 | 0 | 100 | 0 |  | IN | ELOUADRHIRI L | 1 | 1 | D | LATIFA E | 09-030 | 09-030 | 11-026 | 11 -035 | 12-052 | 13-002 | PE | 13-015 | PR |  |  |  | 14-001 |  |  |  |  |  |  |  |  |  |  |  |  |  |
| 24264794 | Solenoid - procure motion system |  | 42d | 2014-05-05 | 2014-07-02 | 24264793 FS-5d |  |  |  |  | 214d | 36d | 8/5 M-F w/JLAB Holidays ReBaseline | PROCUREMENT<$50K 60 | 3,579.66 |  | 24264794 | 3579.66 | 0 | 0 | 100 | 0 |  | IN | ELOUADRHIRI L | 1 | 1 | D | LATIFA E | 09-030 | 09-030 | 11-026 | 11 -035 | 12-052 | 13-002 | PE | 13-015 | PR |  |  |  | 14-001 |  |  |  |  |  |  |  |  |  |  |  |  |  |
| 24264545 | Install and wire up Torus PS (G0) |  | 5d | 2014-05-06 | 2014-05-12 | 9-140M FS+145d |  |  |  |  | 83d | 58d | 8/5 M-F w/JLAB Holidays ReBaseline | ELEC TECH [160 h] | 7,518.4 |  | 24264545 |  |  |  |  | 0 |  |  | ELOUADRHIRI L | 1 | 1 | H | LATIFA E |  |  |  |  | 12-052 | 13-002 |  | 13-015 | PR |  |  | PE | 14-001 |  |  |  |  |  |  |  |  |  |  |  |  |  |
| 24264085M | First Torus Cryostat Ready | milestone | 0d | 2014-05-13 | 2014-05-13 | 242743005 |  |  |  |  | 83d | 58d | 8/5 M-F w/JLAB Holidays ReBaseline |  |  |  | 24264085M |  |  |  |  | 0 |  |  | ELOUADRHIRI L | 1 | 1 | M | LATIFA E |  |  |  |  | 12-052 | 13-002 |  | 13-015 | PR |  |  |  |  |  |  |  |  |  |  |  |  |  |  |  |  |  |
| 24264110 | SVT - Design Insertion/service cart and installation arm |  | 39d | 2014-05-27 | 2014-07-21 | 24264105 |  |  |  |  | 253d | 0d | 8/5 M-F w/JLAB Holidays ReBaseline | MECH DES [200 h] | 10,260 |  | 24264110 |  |  |  |  | 0 |  | IN | ELOUADRHIRI L | 1 | 1 | H | LATIFA E |  |  |  |  | 12-052 | 13-002 |  | 13-015 | PR |  |  | PE | 14-001 |  |  |  |  |  |  |  |  |  |  |  |  |  |
| 24264797 | Solenoid - procure cart |  | 64d | 2014-06-02 | 2014-08-29 | 24264796, 9-140M FS+163d |  |  |  |  | 176d | 269d | 8/5 M-F w/JLAB Holidays ReBaseline | PROCUREMENT<$50K 60 | 54,761.9 |  | 24264797 | 54761.9 | 0 | 0 | 100 | 0 |  | IN | ELOUADRHIRI L | 1 | 1 | D | LATIFA E | 09-030 | 09-030 | 11-026 | 11 -035 | 12-052 | 13-002 | PE | 13-015 | PR |  |  |  | 14-001 |  |  |  |  |  |  |  |  |  |  |  |  |  |
| 24264900 | DC - procure mounts and adjusters for DC to Torus |  | 84d | 2014-06-02 | 2014-09-29 | 24264890, 24264895, 9-140M FS+163d |  |  |  |  | 191d | 166d | 8/5 M-F w/JLAB Holidays ReBaseline | PROCUREMENT<$50K 60 | 78,000.29 |  | 24264900 | 78000.29 | 0 | 0 | 100 | 0 |  | IN | ELOUADRHIRI L | 1 | 1 | D | LATIFA E |  | 09-030 | 11-026 | 11 -035 | 12-052 | 13-002 | PE | 13-015 | PR |  |  |  | 14-001 |  |  |  |  |  | APP | 08-016 | 4211 | 09-012 | 12-027 |  |  |  |
| 24264282 | Design modifications to Lead Nose |  | 15d | 2014-06-04 | 2014-06-24 | 9-140M FS+165d |  |  |  |  | 331d | 0d | 8/5 M-F w/JLAB Holidays ReBaseline | PLABOR | 6,439.06 |  | 24264282 |  |  |  |  | 0 |  | IN | ELOUADRHIRI L | 1 | 1 | H | LATIFA E |  |  |  |  | 12-052 | 13-002 |  | 13-015 | PR |  |  |  | 14-001 |  |  |  |  |  |  |  |  |  |  | PE |  |  |
| 24264285 | Modify Lead nose |  | 13d | 2014-06-25 | 2014-07-14 | 24264278, 24264282 |  |  |  |  | 331d | 199d | 8/5 M-F w/JLAB Holidays ReBaseline | MECH TECH [64 h] | 3,028.48 |  | 24264285 |  |  |  |  | 0 |  |  | ELOUADRHIRI L | 1 | 1 | H | LATIFA E |  |  |  |  | 12-052 | 13-002 |  | 13-015 | PR |  |  | PE | 14-001 |  |  |  |  |  |  |  |  |  |  |  |  |  |
| 24264115 | SVT - Design transportation cart/skid |  | 52d | 2014-07-22 | 2014-10-02 | 24264110 |  |  |  |  | 253d | 0d | 8/5 M-F w/JLAB Holidays ReBaseline | MECH DES [480 h] | 24,624 |  | 24264115 |  |  |  |  | 0 |  | IN | ELOUADRHIRI L | 1 | 1 | S | LATIFA E |  |  |  |  | 12-052 | 13-002 |  | 13-015 | PR |  | ST | PE | 14-001 |  |  |  |  |  |  |  |  |  |  |  |  |  |
| 24264550 | Install 3 Torus Base support and adjustment Stands |  | 5d | 2014-07-22 | 2014-07-28 | 24264548M FS-10d, 242751385, 242751440 |  |  |  |  | 54d | 29d | 8/5 M-F w/JLAB Holidays ReBaseline | MECH DES [20 h]; MECH ENG [20 h]; MECH TECH [160 h] | 10,090.6 |  | 24264550 |  |  |  |  | 0 |  |  | ELOUADRHIRI L | 1 | 1 |  | LATIFA E |  |  |  |  | 12-052 | 13-002 |  | 13-015 | PR |  |  | PE | 14-001 |  |  |  |  |  |  |  |  |  |  |  |  |  |
| 24264090M | Last Torus Cryostat Ready | milestone | 0d | 2014-07-29 | 2014-07-29 | 2-34M |  |  |  |  | 117d | 92d | 8/5 M-F w/JLAB Holidays ReBaseline |  |  |  | 24264090M |  |  |  |  | 0 |  |  | ELOUADRHIRI L | 1 | 1 | M | LATIFA E |  |  |  |  | 12-052 | 13-002 |  | 13-015 | PR |  |  |  |  |  |  |  |  |  |  |  |  |  |  |  |  |  |
| 24264910 | DC - cable trays and gas system mounts Engineering Analysis |  | 23d | 2014-07-31 | 2014-09-02 | 24264905 FS-49d |  |  |  |  | 75d | 25d | 8/5 M-F w/JLAB Holidays ReBaseline | MECH ENG [200 h] | 14,934 |  | 24264910 |  |  |  |  | 0 |  | IN | ELOUADRHIRI L | 1 | 1 | S | LATIFA E |  | 09-030 | 11-026 | 11 -035 | 12-052 | 13-002 |  | 13-015 | PR |  | ST | PE | 14-001 |  |  |  |  |  | APP | 08-016 | 4211 | 09-012 | 12-027 |  |  |  |
| 24264792 | Solenoid - Install and Align rails and adjustment components for solenoid and HTCC rails |  | 15d | 2014-08-04 | 2014-08-22 | 24264791 |  |  |  |  | 178d | 0d | 8/5 M-F w/JLAB Holidays ReBaseline | MECH TECH |  |  | 24264792 |  |  |  |  | 0 |  | IN | ELOUADRHIRI L | 1 | 1 | Z | LATIFA E | 09-030 | 09-030 | 11-026 | 11 -035 | 12-052 | 13-002 |  | 13-015 | PR |  |  | PE |  |  |  |  |  |  |  |  |  |  |  |  |  |  |
| 24264548M | Start Torus Installation | milestone | 0d | 2014-08-04 | 2014-08-04 | 242751415, 242751240, 24264545, 242751250, 24264085M |  |  |  |  | 25d | 0d | 8/5 M-F w/JLAB Holidays ReBaseline |  |  |  | 24264548M |  |  |  |  | 0 |  | IN | ELOUADRHIRI L | 1 | 1 | M | LATIFA E |  |  |  |  | 12-052 | 13-002 |  | 13-015 | PR |  |  |  |  |  |  |  |  |  |  |  |  |  |  |  |  |  |
| 24264565 | Attach cold hub to Coil D |  | 7d | 2014-08-05 | 2014-08-13 | 24264085M, 242751290, 242751180, 24264548M, 242742075 |  |  |  |  | 25d | 0d | 8/5 M-F w/JLAB Holidays ReBaseline | MECH TECH [224 h] | 10,599.68 |  | 24264565 |  |  |  |  | 0 |  |  | ELOUADRHIRI L | 1 | 1 |  | LATIFA E |  |  |  |  | 12-052 | 13-002 |  | 13-015 | PR |  |  | PE | 14-001 |  |  |  |  |  |  |  |  |  |  |  |  |  |
| 24264570 | Attach Center Base Legs to Coil D |  | 7d | 2014-08-14 | 2014-08-22 | 24264565 |  |  |  |  | 25d | 0d | 8/5 M-F w/JLAB Holidays ReBaseline | MECH TECH [224 h] | 10,599.68 |  | 24264570 |  |  |  |  | 0 |  |  | ELOUADRHIRI L | 1 | 1 |  | LATIFA E |  |  |  |  | 12-052 | 13-002 |  | 13-015 | PR |  |  | PE | 14-001 |  |  |  |  |  |  |  |  |  |  |  |  |  |
| 24264575 | Install Temporary Braces to Hall Floor for Coil D and Beam left and right Cold Rings |  | 10d | 2014-08-25 | 2014-09-08 | 24264570 |  |  |  |  | 25d | 0d | 8/5 M-F w/JLAB Holidays ReBaseline | MECH TECH [480 h]; MECH ENG [40 h]; MECH DES [40 h] | 27,752.4 |  | 24264575 |  |  |  |  | 0 |  |  | ELOUADRHIRI L | 1 | 1 |  | LATIFA E |  |  |  |  | 12-052 | 13-002 |  | 13-015 | PR |  |  | PE | 14-001 |  |  |  |  |  |  |  |  |  |  |  |  |  |
| 24264794a | Solenoid - Install motion system |  | 5d | 2014-08-25 | 2014-08-29 | 24264794, 24264792 |  |  |  |  | 178d | 269d | 8/5 M-F w/JLAB Holidays ReBaseline | MECH TECH [80 h] | 3,785.6 |  | 24264794a |  |  |  |  | 0 |  | IN | ELOUADRHIRI L | 1 | 1 | H | LATIFA E | 09-030 | 09-030 | 11-026 | 11 -035 | 12-052 | 13-002 |  | 13-015 | PR |  |  | PE | 14-001 |  |  |  |  |  |  |  |  |  |  |  |  |  |
| 24264120 | SVT - Cart/Skid Engineering analysis |  | 12d | 2014-08-26 | 2014-09-11 | 24264110 FS+25d |  |  |  |  | 268d | 15d | 8/5 M-F w/JLAB Holidays ReBaseline | MECH ENG [240 h] | 17,920.8 |  | 24264120 |  |  |  |  | 0 |  | IN | ELOUADRHIRI L | 1 | 1 | S | LATIFA E |  |  |  |  | 12-052 | 13-002 |  | 13-015 | PR |  | ST | PE | 14-001 |  |  |  |  |  |  |  |  |  |  |  |  |  |
| 24264230 | Subway Level 1 addition wiring Power Dist. |  | 5d | 2014-09-03 | 2014-09-09 | 9-140M FS+228d |  |  |  |  | 191d | 134d | 8/5 M-F w/JLAB Holidays ReBaseline | PROCUREMENT<$50K 60 | 10,987.86 |  | 24264230 | 10987.86 | 0 | 0 | 100 | 0 |  | IN | ELOUADRHIRI L | 1 | 1 | S | LATIFA E |  |  |  |  | 12-052 | 13-002 | PE | 13-015 | PR |  | ST |  | 14-001 |  |  |  |  |  |  |  |  |  |  |  |  |  |
| 24264580 | Install Coil D Assembly |  | 7d | 2014-09-09 | 2014-09-17 | 24264575, 24264550 |  |  |  |  | 25d | 0d | 8/5 M-F w/JLAB Holidays ReBaseline | MECH TECH [336 h]; MECH ENG [56 h] | 20,081.04 |  | 24264580 |  |  |  |  | 0 |  |  | ELOUADRHIRI L | 1 | 1 |  | LATIFA E |  |  |  |  | 12-052 | 13-002 |  | 13-015 | PR |  |  | PE | 14-001 |  |  |  |  |  |  |  |  |  |  |  |  |  |
| 24264585 | Install Beam left and right cold ring beams |  | 10d | 2014-09-18 | 2014-10-01 | 24264580 |  |  |  |  | 25d | 0d | 8/5 M-F w/JLAB Holidays ReBaseline | MECH TECH [320 h] | 15,142.4 |  | 24264585 |  |  |  |  | 0 |  |  | ELOUADRHIRI L | 1 | 1 |  | LATIFA E |  |  |  |  | 12-052 | 13-002 |  | 13-015 | PR |  |  | PE | 14-001 |  |  |  |  |  |  |  |  |  |  |  |  |  |
| 24264005LOE | Installation Engineering Oversight FY15 |  | 246d | 2014-09-30 | 2015-09-29 | 242751010LOE FS-16d |  |  |  |  | 420d | 0d | 8/5 M-F w/JLAB Holidays ReBaseline | SR STAFF [2712 h]; MECH ENG [1699.2 h] | 453,187.1 |  | 24264005LOE |  |  |  |  | 0 |  |  | ELOUADRHIRI L | 1 | 1 | E | LATIFA E | 09-030 | 09-030 | 11-026 | 11 -035 |  |  |  | 13-015 | PR |  |  | PE | 14-001 |  | 100 | 0 | 100 | 100 |  |  |  |  |  |  |  |  |
| 24264145 | HTCC - design transport cart |  | 56d | 2014-10-01 | 2014-12-19 | 9-155M |  |  |  |  | 194d | 0d | 8/5 M-F w/JLAB Holidays ReBaseline | PLABOR; MECH ENG [40 h] | 18,011.26 |  | 24264145 |  |  |  |  | 0 |  | IN | ELOUADRHIRI L | 1 | 1 | S | LATIFA E |  |  |  |  | 12-052 | 13-002 |  | 13-015 | PR |  | ST | PE | 14-001 |  |  |  |  |  |  |  |  |  |  | PE |  |  |
| 24264345 | Install New Tagger Window |  | 3d | 2014-10-01 | 2014-10-03 | 9-155M |  |  |  |  | 301d | 394d | 8/5 M-F w/JLAB Holidays ReBaseline | MECH TECH [72 h] | 3,407.04 |  | 24264345 |  |  |  |  | 0 |  | IN | ELOUADRHIRI L | 1 | 1 | H | LATIFA E |  |  |  |  | 12-052 | 13-002 |  | 13-015 | PR |  |  | PE | 14-001 |  |  |  |  |  |  |  |  |  |  |  |  |  |
| 24264590 | Align Lower Cold ring beams and lock down |  | 7d | 2014-10-02 | 2014-10-10 | 24264585 |  |  |  |  | 25d | 0d | 8/5 M-F w/JLAB Holidays ReBaseline | MECH TECH [336 h] | 15,899.52 |  | 24264590 |  |  |  |  | 0 |  |  | ELOUADRHIRI L | 1 | 1 |  | LATIFA E |  |  |  |  | 12-052 | 13-002 |  | 13-015 | PR |  |  | PE | 14-001 |  |  |  |  |  |  |  |  |  |  |  |  |  |
| 24264125 | SVT - Procure SVT mounts and cart |  | 49d | 2014-10-03 | 2014-12-12 | 24264115, 24264120, 24264110 |  |  |  |  | 253d | 346d | 8/5 M-F w/JLAB Holidays ReBaseline | PROCUREMENT<$50K 60 | 33,137.4 |  | 24264125 | 33137.4 | 0 | 0 | 100 | 0 |  | IN | ELOUADRHIRI L | 1 | 1 | D | LATIFA E |  |  |  |  | 12-052 | 13-002 | PE | 13-015 | PR |  |  |  | 14-001 |  |  |  |  |  |  |  |  |  |  |  |  |  |
| 24264525 | Distribution Can - Transport and position distribution box |  | 2d | 2014-10-03 | 2014-10-06 | 24264520 FS-1d, 242761030, 24264515 |  |  |  |  | 130d | 0d | 8/5 M-F w/JLAB Holidays ReBaseline | MECH TECH [64 h] | 3,028.48 |  | 24264525 |  |  |  |  | 0 |  |  | ELOUADRHIRI L | 1 | 1 | H | LATIFA E |  |  |  |  | 12-052 | 13-002 |  | 13-015 | PR |  |  | PE | 14-001 |  |  |  |  |  |  |  |  |  |  |  |  |  |
| 24264527 | Distribution Can - Connect cold piping with fittings and welding |  | 5d | 2014-10-07 | 2014-10-13 | 24264525 |  |  |  |  | 130d | 0d | 8/5 M-F w/JLAB Holidays ReBaseline | MECH TECH [160 h] | 7,571.2 |  | 24264525 |  |  |  |  | 0 |  |  | ELOUADRHIRI L | 1 | 1 | H | LATIFA E |  |  |  |  | 12-052 | 13-002 |  | 13-015 | PR |  |  | PE | 14-001 |  |  |  |  |  |  |  |  |  |  |  |  |  |
| 24264915 | DC - procure cable trays and gas system mounts |  | 52d | 2014-10-08 | 2014-12-22 | 24264905 FS-1d, 24264910 |  |  |  |  | 50d | 0d | 8/5 M-F w/JLAB Holidays ReBaseline | PROCUREMENT<$50K 60 | 34,536.66 |  | 24264915 | 34536.66 | 0 | 0 | 100 | 0 |  | IN | ELOUADRHIRI L | 1 | 1 | D | LATIFA E |  | 09-030 | 11-026 | 11 -035 | 12-052 | 13-002 | PE | 13-015 | PR |  |  |  | 14-001 |  |  |  |  |  | APP | 08-016 | 4211 | 09-012 | 12-027 |  |  |  |

Notes:
- 24264395: Steps: Cable/test/repair EC sector 1 (done); Cable/test/repair EC sector 2 (done); Cable/test/repair EC sector 3 (done); Cable/test/repair EC sector 4; Cable/test/repair EC sector 5; Cable/test/repair EC sector 6
- 24264300: Steps: Cable Sector 5 (done); Cable Sector 6; Cable Sector 1; Cable Sector 2; Cable Sector 3; Cable Sector 4
- 24264300a: Steps: Cable Sector 5 (done); Cable Sector 6; Cable Sector 1; Cable Sector 2; Cable Sector 3; Cable Sector 4
- 24264890: Steps: DC - design mounts and adjusters for DC to Torus for region 1; DC - design mounts and adjusters for DC to Torus for region 2; DC - design mounts and adjusters for DC to Torus for region 3
- 24264888: Steps: Route gas lines for region 1; Route gas lines for region 2; Route gas lines for region 3
- 24264895: Steps: Hand Calculations; FEA Analysis; Report
- 24264365: Steps: Transport and install sector 1; Transport and install sector 2; Transport and install sector 3; Transport and install sector 4; Transport and install sector 5; Transport and install sector 6
- 24264280: Steps: Design gas piping system; Install piping for sector 1; Install piping for sector 2; Install piping for sector 3; Install piping for sector 4; Install piping for sector 5; Install piping for sector 6
- 24264400: Steps: Transport and Install ToF 1a Sector 1; Transport and Install ToF 1a Sector 2; Transport and Install ToF 1a Sector 3; Transport and Install ToF 1a Sector 4; Transport and Install ToF 1a Sector 5; Transport and Install ToF 1a Sector 6
- 24264410: Steps: Cable/test/repair 1a's TOF's sector 1; Cable/test/repair 1a's TOF's sector 2; Cable/test/repair 1a's TOF's sector 3; Cable/test/repair 1a's TOF's sector 4; Cable/test/repair 1a's TOF's sector 5; Cable/test/repair 1a's TOF's sector 6
- 24264281: Steps: Install supply piping; Install return piping
- 24264795: Steps: Conceptual design; 3D model; Drawings
- 24264905: Steps: Conceptual design; 3D model; Drawings
- 24264430: Steps: Transport and install ToF 1b Sector 1; Transport and install ToF 1b Sector 2; Transport and install ToF 1b Sector 3; Transport and install ToF 1b Sector 4; Transport and install ToF 1b Sector 5; Transport and install ToF 1b Sector 6
- 24264796: Steps: Hand Calculations; FEA Analysis; Report
- 24264440: Steps: Cable/test/repair 1b's TOF's Sector 1; Cable/test/repair 1b's TOF's Sector 2; Cable/test/repair 1b's TOF's Sector 3; Cable/test/repair 1b's TOF's Sector 4; Cable/test/repair 1b's TOF's Sector 5; Cable/test/repair 1b's TOF's Sector 6
- 24264115: Steps: Conceptual design; 3D model; Drawings
- 24264910: Steps: Hand Calculations; FEA Analysis; Report
- 24264120: Steps: Hand Calculations; FEA Analysis; Report
- 24264230: Steps: Determine required wiring; Install wiring
- 24264145: Steps: Conceptual design; 3D model; Drawings

| ID | Activity | Type | Duration | Start | Finish | Predecessors | Total float | Free float | Calendar | Resources | Cost | Original Activity ID Rebaseline | MONTHLY EV COST | PHAS - Project Phase | RESP - Responsibility | STRT%COMP for CM EVM | FNSH%COMP for CM EVM | Advance Purchase Plan > 500K | CR 08-016 | EVMS Reporting Codes | CAM RESPONSIBLE | 12 GEV MAJOR PROCUREMENT CATAGORY | Activities with Steps | CR 09-012 | CR 09-030 Repair | CR 11-026 | CR 11-035 | CR 12-027 | CR 12-052 | CR 13-002 | BOE Expenses | CR 13-015 | Post Rebaseline | CR 14-001 | BOE Labor | Remaining Material Cost Based on % Compl | Claimed Material Cost Based on % Complet | Initial Claimed Material Calc | Claimed Material Divider | BOE Procurement | CR 09-030 | CR 12-024 | CR 13-010 |
| --- | --- | --- | --- | --- | --- | --- | --- | --- | --- | --- | --- | --- | --- | --- | --- | --- | --- | --- | --- | --- | --- | --- | --- | --- | --- | --- | --- | --- | --- | --- | --- | --- | --- | --- | --- | --- | --- | --- | --- | --- | --- | --- | --- |
| 24264920 | DC - design maintenance platforms |  | 60d | 2014-10-10 | 2015-01-15 | 9-155M FS+7d | 166d | 0d | 8/5 M-F w/JLAB Holidays ReBaseline | PLABOR | 10,731.76 | 24264920 | 0 | IN | ELOUADRHIRI L | 1 | 1 | APP | 08-016 | S | LATIFA E | 4211 | ST | 09-012 | 09-030 | 11-026 | 11 -035 | 12-027 | 12-052 | 13-002 | PE | 13-015 | PR | 14-001 |  |  |  |  |  |  |  |  |  |
| 24264595 | Install Coil E and C Assemblies (mechanical) |  | 11d | 2014-10-13 | 2014-10-27 | 242743035, 24264590, 242743015 | 25d | 0d | 8/5 M-F w/JLAB Holidays ReBaseline | MECH TECH [528 h]; MECH ENG [88 h] | 31,555.92 | 24264595 | 0 |  | ELOUADRHIRI L | 1 | 1 |  |  |  | LATIFA E |  |  |  |  |  |  |  | 12-052 | 13-002 |  | 13-015 | PR | 14-001 | PE |  |  |  |  |  |  |  |  |
| 24264529 | Distribution Can - Connect Instrumentation and valves |  | 5d | 2014-10-14 | 2014-10-20 | 24264527 | 130d | 0d | 8/5 M-F w/JLAB Holidays ReBaseline | MECH TECH [160 h] | 7,571.2 | 24264525 | 0 |  | ELOUADRHIRI L | 1 | 1 |  |  | H | LATIFA E |  |  |  |  |  |  |  | 12-052 | 13-002 |  | 13-015 | PR | 14-001 | PE |  |  |  |  |  |  |  |  |
| 24264531 | Distribution Can - leak test system |  | 4d | 2014-10-21 | 2014-10-24 | 24264529 | 130d | 0d | 8/5 M-F w/JLAB Holidays ReBaseline | MECH TECH [128 h] | 6,056.96 | 24264525 | 0 |  | ELOUADRHIRI L | 1 | 1 |  |  | H | LATIFA E |  |  |  |  |  |  |  | 12-052 | 13-002 |  | 13-015 | PR | 14-001 | PE |  |  |  |  |  |  |  |  |
| 24264095M | Torus Control System Ready for Installation | milestone | 0d | 2014-10-22 | 2014-10-22 | 24271740M FS+60d | 182d | 0d | 8/5 M-F w/JLAB Holidays ReBaseline |  |  | 24264095M | 0 |  | ELOUADRHIRI L | 1 | 1 |  |  | M | LATIFA E |  |  |  |  |  |  |  | 12-052 | 13-002 |  | 13-015 | PR |  |  |  |  |  |  |  |  |  |  |
| 24264555 | Install Torus Control System |  | 20d | 2014-10-22 | 2014-11-18 | 24264095M | 182d | 157d | 8/5 M-F w/JLAB Holidays ReBaseline | ELEC TECH [160 h]; ELEC ENG [160 h] | 19,539.2 | 24264555 | 0 |  | ELOUADRHIRI L | 1 | 1 |  |  |  | LATIFA E |  |  |  |  |  |  |  | 12-052 | 13-002 |  | 13-015 | PR | 14-001 | PE |  |  |  |  |  |  |  |  |
| 24264533 | Distribution Can - pressure test system |  | 2d | 2014-10-27 | 2014-10-28 | 24264531 | 130d | 0d | 8/5 M-F w/JLAB Holidays ReBaseline | MECH TECH [64 h] | 3,028.48 | 24264525 | 0 |  | ELOUADRHIRI L | 1 | 1 |  |  | H | LATIFA E |  |  |  |  |  |  |  | 12-052 | 13-002 |  | 13-015 | PR | 14-001 | PE |  |  |  |  |  |  |  |  |
| 24264600 | Install Vertical Cold ring beams and braces |  | 10d | 2014-10-28 | 2014-11-10 | 24264595 | 25d | 0d | 8/5 M-F w/JLAB Holidays ReBaseline | MECH TECH [320 h] | 15,142.4 | 24264600 | 0 |  | ELOUADRHIRI L | 1 | 1 |  |  |  | LATIFA E |  |  |  |  |  |  |  | 12-052 | 13-002 |  | 13-015 | PR | 14-001 | PE |  |  |  |  |  |  |  |  |
| 24264535 | Distribution Can - final leak test system |  | 3d | 2014-10-29 | 2014-10-31 | 24264533 | 130d | 0d | 8/5 M-F w/JLAB Holidays ReBaseline | MECH TECH [96 h] | 4,542.72 | 24264525 | 0 |  | ELOUADRHIRI L | 1 | 1 |  |  | H | LATIFA E |  |  |  |  |  |  |  | 12-052 | 13-002 |  | 13-015 | PR | 14-001 | PE |  |  |  |  |  |  |  |  |
| 24264540 | Distribution Can - purify system |  | 3d | 2014-11-03 | 2014-11-05 | 24264535 | 130d | 92d | 8/5 M-F w/JLAB Holidays ReBaseline | MECH TECH [80 h] | 3,785.6 | 24264525 | 0 |  | ELOUADRHIRI L | 1 | 1 |  |  | H | LATIFA E |  |  |  |  |  |  |  | 12-052 | 13-002 |  | 13-015 | PR | 14-001 | PE |  |  |  |  |  |  |  |  |
| 24264605 | Install Coil F and B assemblies |  | 11d | 2014-11-11 | 2014-11-25 | 242743055, 242743075, 24264600 | 25d | 0d | 8/5 M-F w/JLAB Holidays ReBaseline | MECH TECH [528 h]; MECH ENG [88 h] | 31,555.92 | 24264605 | 0 |  | ELOUADRHIRI L | 1 | 1 |  |  |  | LATIFA E |  |  |  |  |  |  |  | 12-052 | 13-002 |  | 13-015 | PR | 14-001 | PE |  |  |  |  |  |  |  |  |
| 24264610 | Install Top four Cold Ring beams and temporary braces |  | 7d | 2014-11-26 | 2014-12-08 | 24264605 | 25d | 0d | 8/5 M-F w/JLAB Holidays ReBaseline | MECH TECH [224 h] | 10,599.68 | 24264610 | 0 |  | ELOUADRHIRI L | 1 | 1 |  |  |  | LATIFA E |  |  |  |  |  |  |  | 12-052 | 13-002 |  | 13-015 | PR | 14-001 | PE |  |  |  |  |  |  |  |  |
| 24264925 | DC - maintenance platforms Engineering Analysis |  | 15d | 2014-12-01 | 2014-12-19 | 24264920 FS-26d | 166d | 0d | 8/5 M-F w/JLAB Holidays ReBaseline | MECH ENG [120 h] | 8,960.4 | 24264925 | 0 | IN | ELOUADRHIRI L | 1 | 1 | APP | 08-016 | H | LATIFA E | 4211 |  | 09-012 | 09-030 | 11-026 | 11 -035 | 12-027 | 12-052 | 13-002 |  | 13-015 | PR | 14-001 | PE |  |  |  |  |  |  |  |  |
| 24264615 | Install Coil A |  | 6d | 2014-12-09 | 2014-12-16 | 24264610, 24264090M, 242743095 | 25d | 0d | 8/5 M-F w/JLAB Holidays ReBaseline | MECH TECH [288 h]; MECH ENG [24 h]; MECH DES [24 h] | 16,651.44 | 24264615 | 0 |  | ELOUADRHIRI L | 1 | 1 |  |  |  | LATIFA E |  |  |  |  |  |  |  | 12-052 | 13-002 |  | 13-015 | PR | 14-001 | PE |  |  |  |  |  |  |  |  |
| 24264620 | Survey all CCM and Cold Hub relative locations adjust as necessary |  | 3d | 2014-12-17 | 2014-12-19 | 24264615 | 25d | 0d | 8/5 M-F w/JLAB Holidays ReBaseline | MECH ENG [24 h]; MECH TECH [108 h] | 6,902.64 | 24264620 | 0 |  | ELOUADRHIRI L | 1 | 1 |  |  |  | LATIFA E |  |  |  |  |  |  |  | 12-052 | 13-002 |  | 13-015 | PR | 14-001 | PE |  |  |  |  |  |  |  |  |
| 24264160 | HTCC - procure transport cart |  | 41d | 2014-12-22 | 2015-02-27 | 24264145 | 194d | 166d | 8/5 M-F w/JLAB Holidays ReBaseline | PROCUREMENT<$50K 60 | 36,629.35 | 24264160 | 0 | IN | ELOUADRHIRI L | 1 | 1 |  |  | D | LATIFA E |  |  |  |  |  |  |  | 12-052 | 13-002 |  | 13-015 | PR | 14-001 |  | 36629.35 | 0 | 0 | 100 | PE |  |  |  |
| 24264625 | Mount the Torus Service Module on Level 3 |  | 1d | 2014-12-22 | 2014-12-22 | 24264620, 242751335 | 25d | 0d | 8/5 M-F w/JLAB Holidays ReBaseline | MECH TECH [32 h]; MECH DES [4 h] | 1,719.44 | 24264625 | 0 |  | ELOUADRHIRI L | 1 | 1 |  |  |  | LATIFA E |  |  |  |  |  |  |  | 12-052 | 13-002 |  | 13-015 | PR | 14-001 | PE |  |  |  |  |  |  |  |  |
| 24264930 | DC - procure maintenance platforms |  | 41d | 2014-12-22 | 2015-02-27 | 24264920 FS-20d, 24264925 | 166d | 141d | 8/5 M-F w/JLAB Holidays ReBaseline | PROCUREMENT<$50K 60 | 19,836.21 | 24264930 | 0 | IN | ELOUADRHIRI L | 1 | 1 | APP | 08-016 | D | LATIFA E | 4211 |  | 09-012 | 09-030 | 11-026 | 11 -035 | 12-027 | 12-052 | 13-002 |  | 13-015 | PR | 14-001 |  | 19836.21 | 0 | 0 | 100 | PE |  |  |  |
| 24264630 | Splice all Coil Leads and Leads to Service Module |  | 4d | 2014-12-23 | 2015-01-07 | 24264625 | 25d | 0d | 8/5 M-F w/JLAB Holidays ReBaseline | MECH ENG [32 h]; MECH TECH [96 h] | 6,932.16 | 24264630 | 0 |  | ELOUADRHIRI L | 1 | 1 |  |  |  | LATIFA E |  |  |  |  |  |  |  | 12-052 | 13-002 |  | 13-015 | PR | 14-001 | PE |  |  |  |  |  |  |  |  |
| 24264635 | Weld/Braze all cooling lines (He) |  | 2d | 2015-01-08 | 2015-01-09 | 24264630 | 25d | 0d | 8/5 M-F w/JLAB Holidays ReBaseline | MECH TECH [48 h] | 2,271.36 | 24264635 | 0 |  | ELOUADRHIRI L | 1 | 1 |  |  |  | LATIFA E |  |  |  |  |  |  |  | 12-052 | 13-002 |  | 13-015 | PR | 14-001 | PE |  |  |  |  |  |  |  |  |
| 24264640 | Pressure and Leak test all 4K cooling lines |  | 2d | 2015-01-12 | 2015-01-13 | 24264635 | 25d | 0d | 8/5 M-F w/JLAB Holidays ReBaseline | MECH TECH [32 h]; MECH ENG [16 h] | 2,708.96 | 24264640 | 0 |  | ELOUADRHIRI L | 1 | 1 |  |  |  | LATIFA E |  |  |  |  |  |  |  | 12-052 | 13-002 |  | 13-015 | PR | 14-001 | PE |  |  |  |  |  |  |  |  |
| 24264880 | Vend Fab Drift Chambers Installation tooling |  | 100d | 2015-01-12 | 2015-06-03 | 9-155M FS+65d | 100d | 75d | 8/5 M-F w/JLAB Holidays ReBaseline | PROCUREMENT<$50K 60 | 21,060.11 | 24264880 | 0 | IN | ELOUADRHIRI L | 1 | 1 |  |  | D | LATIFA E |  |  |  | 09-030 | 11-026 | 11 -035 | 12-027 | 12-052 | 13-002 |  | 13-015 | PR | 14-001 |  | 21060.11 | 0 | 0 | 100 | PE | 09-030 |  |  |
| 24264645 | Secure and Heat Station the Splices and coil leads |  | 3d | 2015-01-14 | 2015-01-16 | 24264640 | 25d | 0d | 8/5 M-F w/JLAB Holidays ReBaseline | MECH TECH [72 h] | 3,407.04 | 24264645 | 0 |  | ELOUADRHIRI L | 1 | 1 |  |  |  | LATIFA E |  |  |  |  |  |  |  | 12-052 | 13-002 |  | 13-015 | PR | 14-001 | PE |  |  |  |  |  |  |  |  |
| 24264650 | Connect all instrumentation including voltage taps |  | 6d | 2015-01-20 | 2015-01-27 | 24264645 | 25d | 0d | 8/5 M-F w/JLAB Holidays ReBaseline | MECH TECH [96 h]; ELEC TECH [96 h] | 9,053.76 | 24264650 | 0 |  | ELOUADRHIRI L | 1 | 1 |  |  |  | LATIFA E |  |  |  |  |  |  |  | 12-052 | 13-002 |  | 13-015 | PR | 14-001 | PE |  |  |  |  |  |  |  |  |
| 24264655 | Insulate all 4K Surfaces |  | 10d | 2015-01-28 | 2015-02-10 | 24264650, 242751260, 242751310, 242751300 | 25d | 0d | 8/5 M-F w/JLAB Holidays ReBaseline | MECH DES [40 h]; MECH ENG [40 h]; MECH TECH [320 h] | 20,181.2 | 24264655 | 0 |  | ELOUADRHIRI L | 1 | 1 |  |  |  | LATIFA E |  |  |  |  |  |  |  | 12-052 | 13-002 |  | 13-015 | PR | 14-001 | PE |  |  |  |  |  |  |  |  |
| 24264010M | SVT Ready For Installation | milestone | 0d | 2015-02-05 | 2015-02-05 | 242211918M | 200d | 293d | 8/5 M-F w/JLAB Holidays ReBaseline |  |  | 24264010M | 0 |  | ELOUADRHIRI L | 1 | 1 |  |  | M | LATIFA E |  |  |  |  |  |  |  | 12-052 | 13-002 |  | 13-015 | PR |  |  |  |  |  |  |  |  |  |  |
| 24264660 | Complete Central hub heat shield |  | 4d | 2015-02-11 | 2015-02-16 | 24264655 | 25d | 0d | 8/5 M-F w/JLAB Holidays ReBaseline | MECH TECH [96 h] | 4,542.72 | 24264660 | 0 |  | ELOUADRHIRI L | 1 | 1 |  |  |  | LATIFA E |  |  |  |  |  |  |  | 12-052 | 13-002 |  | 13-015 | PR | 14-001 | PE |  |  |  |  |  |  |  |  |
| 24264762 | TORUS CRYO WARM PIPING-Design Gas Panel and Piping |  | 15d | 2015-02-12 | 2015-03-04 | 24264760 FS-70d | 37d | 0d | 8/5 M-F w/JLAB Holidays ReBaseline | MECH ENG [120 h] | 8,960.4 | 24264762 | 0 |  | ELOUADRHIRI L | 1 | 1 |  |  |  | LATIFA E |  |  |  |  |  |  |  | 12-052 | 13-002 | PE | 13-015 | PR | 14-001 | PE |  |  |  |  |  |  |  |  |
| 24264665 | Install Cold to warm supports on vertical Cold ring beams |  | 1d | 2015-02-17 | 2015-02-17 | 24264660 | 25d | 0d | 8/5 M-F w/JLAB Holidays ReBaseline | MECH TECH [32 h]; MECH ENG [4 h]; MECH DES [4 h] | 2,018.12 | 24264665 | 0 |  | ELOUADRHIRI L | 1 | 1 |  |  |  | LATIFA E |  |  |  |  |  |  |  | 12-052 | 13-002 |  | 13-015 | PR | 14-001 | PE |  |  |  |  |  |  |  |  |
| 24264670 | Install Heat shield on Cold Ring vertical Beams |  | 4d | 2015-02-18 | 2015-02-23 | 24264665 | 25d | 0d | 8/5 M-F w/JLAB Holidays ReBaseline | MECH TECH [128 h] | 6,056.96 | 24264670 | 0 |  | ELOUADRHIRI L | 1 | 1 |  |  |  | LATIFA E |  |  |  |  |  |  |  | 12-052 | 13-002 |  | 13-015 | PR | 14-001 | PE |  |  |  |  |  |  |  |  |
| 24264675 | Insulate 80K surfaces on Cold Ring vertical beams |  | 4d | 2015-02-24 | 2015-02-27 | 24264670 | 25d | 0d | 8/5 M-F w/JLAB Holidays ReBaseline | MECH TECH [128 h]; MECH ENG [16 h]; MECH DES [16 h] | 8,072.48 | 24264675 | 0 |  | ELOUADRHIRI L | 1 | 1 |  |  |  | LATIFA E |  |  |  |  |  |  |  | 12-052 | 13-002 |  | 13-015 | PR | 14-001 | PE |  |  |  |  |  |  |  |  |
| 24264680 | Install Outer Legs N & S on Adjusters (includes 1/2 of CS VJ) |  | 2d | 2015-03-02 | 2015-03-03 | 24264675 | 25d | 0d | 8/5 M-F w/JLAB Holidays ReBaseline | MECH ENG [16 h]; MECH TECH [112 h] | 6,494.56 | 24264680 | 0 |  | ELOUADRHIRI L | 1 | 1 |  |  |  | LATIFA E |  |  |  |  |  |  |  | 12-052 | 13-002 |  | 13-015 | PR | 14-001 | PE |  |  |  |  |  |  |  |  |
| 24264685 | Attach cold to warm support to VJ (2 places) |  | 1d | 2015-03-04 | 2015-03-04 | 24264680 | 25d | 0d | 8/5 M-F w/JLAB Holidays ReBaseline | MECH TECH [32 h]; MECH ENG [8 h] | 2,111.6 | 24264685 | 0 |  | ELOUADRHIRI L | 1 | 1 |  |  |  | LATIFA E |  |  |  |  |  |  |  | 12-052 | 13-002 |  | 13-015 | PR | 14-001 | PE |  |  |  |  |  |  |  |  |
| 24264690 | Complete Vertical Cold Ring VJ |  | 4d | 2015-03-05 | 2015-03-10 | 24264685 | 25d | 0d | 8/5 M-F w/JLAB Holidays ReBaseline | MECH ENG [32 h]; MECH TECH [224 h] | 12,989.12 | 24264690 | 0 |  | ELOUADRHIRI L | 1 | 1 |  |  |  | LATIFA E |  |  |  |  |  |  |  | 12-052 | 13-002 |  | 13-015 | PR | 14-001 | PE |  |  |  |  |  |  |  |  |
| 24264762A | TORUS CRYO WARM PIPING-Cut Back Piping |  | 1d | 2015-03-05 | 2015-03-05 | 24264762 | 37d | 0d | 8/5 M-F w/JLAB Holidays ReBaseline | MECH TECH [16 h] | 757.12 | 24264762 | 0 |  | ELOUADRHIRI L | 1 | 1 |  |  |  | LATIFA E |  |  |  |  |  |  |  | 12-052 | 13-002 | PE | 13-015 | PR | 14-001 | PE |  |  |  |  |  |  |  |  |
| 24264762B | TORUS CRYO WARM PIPING-Procure valves and fitting |  | 20d | 2015-03-06 | 2015-04-02 | 24264762A | 37d | 0d | 8/5 M-F w/JLAB Holidays ReBaseline | MECH ENG [160 h]; SUPPLIES & MATERIALS | 22,266.2 | 24264762 | 0 |  | ELOUADRHIRI L | 1 | 1 |  |  |  | LATIFA E |  |  |  |  |  |  |  | 12-052 | 13-002 | PE | 13-015 | PR | 14-001 | PE |  |  |  |  |  |  |  |  |
| 24264695 | Transfer load from Temporary legs to Outer Legs and Remove Temp legs |  | 2d | 2015-03-11 | 2015-03-12 | 24264690 | 25d | 0d | 8/5 M-F w/JLAB Holidays ReBaseline | MECH ENG [8 h]; MECH DES [8 h]; MECH TECH [64 h] | 4,036.24 | 24264695 | 0 |  | ELOUADRHIRI L | 1 | 1 |  |  |  | LATIFA E |  |  |  |  |  |  |  | 12-052 | 13-002 |  | 13-015 | PR | 14-001 | PE |  |  |  |  |  |  |  |  |
| 24264700 | Install Heat Shield on other 8 Hex Ring beams |  | 8d | 2015-03-13 | 2015-03-24 | 24264695 | 25d | 0d | 8/5 M-F w/JLAB Holidays ReBaseline | MECH ENG [64 h]; MECH TECH [448 h] | 25,978.24 | 24264700 | 0 |  | ELOUADRHIRI L | 1 | 1 |  |  |  | LATIFA E |  |  |  |  |  |  |  | 12-052 | 13-002 |  | 13-015 | PR | 14-001 | PE |  |  |  |  |  |  |  |  |
| 24264705 | Connect all Heat Shield cooling tubes |  | 3d | 2015-03-25 | 2015-03-27 | 24264700 | 25d | 0d | 8/5 M-F w/JLAB Holidays ReBaseline | MECH TECH [96 h] | 4,542.72 | 24264705 | 0 |  | ELOUADRHIRI L | 1 | 1 |  |  |  | LATIFA E |  |  |  |  |  |  |  | 12-052 | 13-002 |  | 13-015 | PR | 14-001 | PE |  |  |  |  |  |  |  |  |
| 24264710 | Pressure and Leak test all 80K cooling lines |  | 2d | 2015-03-30 | 2015-03-31 | 24264705 | 25d | 0d | 8/5 M-F w/JLAB Holidays ReBaseline | MECH TECH [32 h]; MECH ENG [16 h] | 2,708.96 | 24264710 | 0 |  | ELOUADRHIRI L | 1 | 1 |  |  |  | LATIFA E |  |  |  |  |  |  |  | 12-052 | 13-002 |  | 13-015 | PR | 14-001 | PE |  |  |  |  |  |  |  |  |
| 24264757 | TORUS CRYOTOWER-Transport and position cryotower |  | 2d | 2015-03-31 | 2015-04-01 | 24264690, 24264525 FS-1d, 242762045, 24264540 | 38d | 0d | 8/5 M-F w/JLAB Holidays ReBaseline | MECH TECH [48 h] | 2,271.36 | 24264757 | 0 |  | ELOUADRHIRI L | 1 | 1 |  |  |  | LATIFA E |  |  |  |  |  |  |  | 12-052 | 13-002 |  | 13-015 | PR | 14-001 | PE |  |  |  |  |  |  |  |  |
| 24264715 | Insulate All 80K Surfaces |  | 6d | 2015-04-01 | 2015-04-08 | 24264710 | 25d | 0d | 8/5 M-F w/JLAB Holidays ReBaseline | MECH ENG [24 h]; MECH DES [24 h]; MECH TECH [192 h] | 12,108.72 | 24264715 | 0 |  | ELOUADRHIRI L | 1 | 1 |  |  |  | LATIFA E |  |  |  |  |  |  |  | 12-052 | 13-002 |  | 13-015 | PR | 14-001 | PE |  |  |  |  |  |  |  |  |
| 24264757A | TORUS CRYOTOWER-Connect cold piping with fittings and welding |  | 10d | 2015-04-02 | 2015-04-15 | 24264757 | 38d | 0d | 8/5 M-F w/JLAB Holidays ReBaseline | MECH TECH [240 h] | 11,356.8 | 24264757 | 0 |  | ELOUADRHIRI L | 1 | 1 |  |  |  | LATIFA E |  |  |  |  |  |  |  | 12-052 | 13-002 |  | 13-015 | PR | 14-001 | PE |  |  |  |  |  |  |  |  |
| 24264757B | TORUS CRYOTOWER-Connect Instrumentation, valves and current leads |  | 8d | 2015-04-02 | 2015-04-13 | 24264757A FS-10d | 38d | 0d | 8/5 M-F w/JLAB Holidays ReBaseline | MECH TECH [192 h] | 9,085.44 | 24264757 | 0 |  | ELOUADRHIRI L | 1 | 1 |  |  |  | LATIFA E |  |  |  |  |  |  |  | 12-052 | 13-002 |  | 13-015 | PR | 14-001 | PE |  |  |  |  |  |  |  |  |
| 24264762C | TORUS CRYO WARM PIPING-Install New Piping |  | 10d | 2015-04-03 | 2015-04-16 | 24264762B | 37d | 0d | 8/5 M-F w/JLAB Holidays ReBaseline | MECH TECH [160 h] | 7,571.2 | 24264762 | 0 |  | ELOUADRHIRI L | 1 | 1 |  |  |  | LATIFA E |  |  |  |  |  |  |  | 12-052 | 13-002 | PE | 13-015 | PR | 14-001 | PE |  |  |  |  |  |  |  |  |
| 24264868 | Design and install HTCC gas system |  | 90d | 2015-04-07 | 2015-08-13 | 9-155M FS+124d | 78d | 50d | 8/5 M-F w/JLAB Holidays ReBaseline | MECH TECH [240 h]; MECH DES [120 h] | 17,512.8 | 24264868 | 0 |  | ELOUADRHIRI L | 1 | 1 |  |  | S | LATIFA E |  | ST |  |  |  | 11 -035 |  | 12-052 | 13-002 |  | 13-015 | PR | 14-001 | PE |  |  |  |  |  |  | 12-024 | 13-010 |
| 24264720 | Install VJ on other 8 Hex Ring Beams |  | 8d | 2015-04-09 | 2015-04-20 | 24264715 | 25d | 0d | 8/5 M-F w/JLAB Holidays ReBaseline | MECH TECH [448 h]; MECH ENG [64 h] | 25,978.24 | 24264720 | 0 |  | ELOUADRHIRI L | 1 | 1 |  |  |  | LATIFA E |  |  |  |  |  |  |  | 12-052 | 13-002 |  | 13-015 | PR | 14-001 | PE |  |  |  |  |  |  |  |  |
| 24264340M | Start Beamline Modifications | milestone | 0d | 2015-04-13 | 2015-04-13 | 24254120 FS-120d | 152d | 0d | 8/5 M-F w/JLAB Holidays ReBaseline |  |  | 24264340M | 0 | IN | ELOUADRHIRI L | 1 | 1 |  |  | M | LATIFA E |  |  |  |  |  |  |  | 12-052 | 13-002 |  | 13-015 | PR |  |  |  |  |  |  |  |  |  |  |
| 24264350 | Move Moeller Quads and Table |  | 15d | 2015-04-13 | 2015-05-01 | 24264340M | 152d | 0d | 8/5 M-F w/JLAB Holidays ReBaseline | MECH TECH [240 h] | 11,356.8 | 24264350 | 0 | IN | ELOUADRHIRI L | 1 | 1 |  |  | S | LATIFA E |  | ST |  |  |  |  |  | 12-052 | 13-002 |  | 13-015 | PR | 14-001 | PE |  |  |  |  |  |  |  |  |
| 24264757C | TORUS CRYOTOWER-Leak Test new System |  | 4d | 2015-04-14 | 2015-04-17 | 24264757B | 38d | 0d | 8/5 M-F w/JLAB Holidays ReBaseline | MECH TECH [96 h] | 4,542.72 | 24264757 | 0 |  | ELOUADRHIRI L | 1 | 1 |  |  |  | LATIFA E |  |  |  |  |  |  |  | 12-052 | 13-002 |  | 13-015 | PR | 14-001 | PE |  |  |  |  |  |  |  |  |
| 24264762D | TORUS CRYO WARM PIPING-Leak Test new Piping |  | 4d | 2015-04-17 | 2015-04-22 | 24264762C | 37d | 0d | 8/5 M-F w/JLAB Holidays ReBaseline | MECH TECH [64 h] | 3,028.48 | 24264762 | 0 |  | ELOUADRHIRI L | 1 | 1 |  |  |  | LATIFA E |  |  |  |  |  |  |  | 12-052 | 13-002 | PE | 13-015 | PR | 14-001 | PE |  |  |  |  |  |  |  |  |
| 24264757D | TORUS CRYOTOWER-Pressure Test Piping |  | 2d | 2015-04-20 | 2015-04-21 | 24264757C | 38d | 0d | 8/5 M-F w/JLAB Holidays ReBaseline | MECH TECH [48 h] | 2,271.36 | 24264757 | 0 |  | ELOUADRHIRI L | 1 | 1 |  |  |  | LATIFA E |  |  |  |  |  |  |  | 12-052 | 13-002 |  | 13-015 | PR | 14-001 | PE |  |  |  |  |  |  |  |  |
| 24264723 | Install insulation and shield and VJ at central Hub |  | 4d | 2015-04-21 | 2015-04-24 | 24264720 | 25d | 0d | 8/5 M-F w/JLAB Holidays ReBaseline | MECH DES [16 h]; MECH ENG [16 h]; MECH TECH [64 h] | 5,044 | 24264723 | 0 |  | ELOUADRHIRI L | 1 | 1 |  |  |  | LATIFA E |  |  |  |  |  |  |  | 12-052 | 13-002 |  | 13-015 | PR | 14-001 | PE |  |  |  |  |  |  |  | 13-010 |
| 24264757F | TORUS CRYOTOWER-Final Leak Test system |  | 3d | 2015-04-22 | 2015-04-24 | 24264757D | 38d | 0d | 8/5 M-F w/JLAB Holidays ReBaseline | MECH TECH [72 h] | 3,407.04 | 24264757 | 0 |  | ELOUADRHIRI L | 1 | 1 |  |  |  | LATIFA E |  |  |  |  |  |  |  | 12-052 | 13-002 |  | 13-015 | PR | 14-001 | PE |  |  |  |  |  |  |  |  |
| 24264762F | TORUS CRYO WARM PIPING-Pressure Test Piping |  | 1d | 2015-04-23 | 2015-04-23 | 24264762D | 37d | 0d | 8/5 M-F w/JLAB Holidays ReBaseline | MECH TECH [16 h] | 757.12 | 24264762 | 0 |  | ELOUADRHIRI L | 1 | 1 |  |  |  | LATIFA E |  |  |  |  |  |  |  | 12-052 | 13-002 | PE | 13-015 | PR | 14-001 | PE |  |  |  |  |  |  |  |  |
| 24264762G | TORUS CRYO WARM PIPING-Final Leak Test system |  | 4d | 2015-04-24 | 2015-04-29 | 24264762F | 37d | 0d | 8/5 M-F w/JLAB Holidays ReBaseline | MECH TECH [64 h] | 3,028.48 | 24264762 | 0 |  | ELOUADRHIRI L | 1 | 1 |  |  |  | LATIFA E |  |  |  |  |  |  |  | 12-052 | 13-002 | PE | 13-015 | PR | 14-001 | PE |  |  |  |  |  |  |  |  |
| 24264065M | LTCC - Last 3 units Ready for Installation | milestone | 0d | 2015-04-27 | 2015-04-27 | 242242500M | 132d | 0d | 8/5 M-F w/JLAB Holidays ReBaseline |  |  | 24264065M | 0 |  | ELOUADRHIRI L | 1 | 1 |  |  | M | LATIFA E |  |  |  |  |  |  |  | 12-052 | 13-002 |  | 13-015 | PR |  |  |  |  |  |  |  |  |  |  |
| 24264725 | Install VJ between Coils at Hub |  | 6d | 2015-04-27 | 2015-05-04 | 24264723 | 25d | 0d | 8/5 M-F w/JLAB Holidays ReBaseline | MECH ENG [48 h]; MECH TECH [336 h] | 19,483.68 | 24264725 | 0 |  | ELOUADRHIRI L | 1 | 1 |  |  |  | LATIFA E |  |  |  |  |  |  |  | 12-052 | 13-002 |  | 13-015 | PR | 14-001 | PE |  |  |  |  |  |  |  |  |
| 24264757G | Purify System |  | 3d | 2015-04-27 | 2015-04-29 | 24264757F | 38d | 13d | 8/5 M-F w/JLAB Holidays ReBaseline | MECH TECH [60 h] | 2,839.2 | 24264757 | 0 |  | ELOUADRHIRI L | 1 | 1 |  |  |  | LATIFA E |  |  |  |  |  |  |  | 12-052 | 13-002 |  | 13-015 | PR | 14-001 | PE |  |  |  |  |  |  |  |  |
| 24264762H | TORUS CRYO WARM PIPING-Purify System |  | 3d | 2015-04-30 | 2015-05-04 | 24264762G | 37d | 12d | 8/5 M-F w/JLAB Holidays ReBaseline | MECH TECH [40 h] | 1,892.8 | 24264762 | 0 |  | ELOUADRHIRI L | 1 | 1 |  |  |  | LATIFA E |  |  |  |  |  |  |  | 12-052 | 13-002 | PE | 13-015 | PR | 14-001 | PE |  |  |  |  |  |  |  |  |
| 24264355 | Move GONI |  | 7d | 2015-05-04 | 2015-05-12 | 24264350 | 152d | 0d | 8/5 M-F w/JLAB Holidays ReBaseline | MECH TECH [80 h] | 3,785.6 | 24264355 | 0 |  | ELOUADRHIRI L | 1 | 1 |  |  | H | LATIFA E |  |  |  |  |  |  |  | 12-052 | 13-002 |  | 13-015 | PR | 14-001 | PE |  |  |  |  |  |  |  |  |
| 24264730 | Transfer All Cold Mass Loads to VJ |  | 2d | 2015-05-05 | 2015-05-06 | 24264725 | 25d | 0d | 8/5 M-F w/JLAB Holidays ReBaseline | MECH TECH [64 h]; MECH ENG [16 h] | 4,223.2 | 24264730 | 0 |  | ELOUADRHIRI L | 1 | 1 |  |  |  | LATIFA E |  |  |  |  |  |  |  | 12-052 | 13-002 |  | 13-015 | PR | 14-001 | PE |  |  |  |  |  |  |  |  |
| 24264460 | Transport and Install LTCC |  | 10d | 2015-05-06 | 2015-05-19 | 24264055M FS-4d, 24264285, 24264430 FS-4d, 24264435 FS-4d, 24264065M FS+7d | 132d | 0d | 8/5 M-F w/JLAB Holidays ReBaseline | MECH TECH [320 h] | 15,142.4 | 24264460 | 0 |  | ELOUADRHIRI L | 1 | 1 |  |  | S | LATIFA E |  | ST |  |  |  |  |  | 12-052 | 13-002 |  | 13-015 | PR | 14-001 | PE |  |  |  |  |  |  |  |  |
| 24264735 | Align VJ to Beam Line |  | 2d | 2015-05-07 | 2015-05-08 | 24264730 | 25d | 0d | 8/5 M-F w/JLAB Holidays ReBaseline | MECH ENG [16 h]; MECH TECH [72 h] | 4,601.76 | 24264735 | 0 |  | ELOUADRHIRI L | 1 | 1 |  |  |  | LATIFA E |  |  |  |  |  |  |  | 12-052 | 13-002 |  | 13-015 | PR | 14-001 | PE |  |  |  |  |  |  |  |  |
| 24264740 | Align Cold Mass to VJ and Beam Line |  | 2d | 2015-05-11 | 2015-05-12 | 24264735 | 25d | 0d | 8/5 M-F w/JLAB Holidays ReBaseline | MECH TECH [72 h]; MECH ENG [16 h] | 4,601.76 | 24264740 | 0 |  | ELOUADRHIRI L | 1 | 1 |  |  |  | LATIFA E |  |  |  |  |  |  |  | 12-052 | 13-002 |  | 13-015 | PR | 14-001 | PE |  |  |  |  |  |  |  |  |
| 24264360 | Align Goni and Moeller Quads |  | 3d | 2015-05-13 | 2015-05-15 | 24264355 | 152d | 245d | 8/5 M-F w/JLAB Holidays ReBaseline | MECH TECH [24 h] | 1,135.68 | 24264360 | 0 |  | ELOUADRHIRI L | 1 | 1 |  |  | H | LATIFA E |  |  |  |  |  |  |  | 12-052 | 13-002 |  | 13-015 | PR | 14-001 | PE |  |  |  |  |  |  |  |  |
| 24264755 | Close up all cold mass view ports and temporary CCM support ports |  | 4d | 2015-05-13 | 2015-05-18 | 24264740 | 25d | 0d | 8/5 M-F w/JLAB Holidays ReBaseline | MECH TECH [96 h] | 4,542.72 | 24264755 | 0 |  | ELOUADRHIRI L | 1 | 1 |  |  |  | LATIFA E |  |  |  |  |  |  |  | 12-052 | 13-002 |  | 13-015 | PR | 14-001 | PE |  |  |  |  |  |  |  | 13-010 |
| 24264760 | TORUS CRYO WARM PIPING-Install Vacuum pumping system |  | 2d | 2015-05-19 | 2015-05-20 | 24264757G, 24264755 | 25d | 0d | 8/5 M-F w/JLAB Holidays ReBaseline | MECH TECH [72 h]; MECH ENG [16 h]; ELEC TECH [16 h] | 5,353.6 | 24264760 | 0 |  | ELOUADRHIRI L | 1 | 1 |  |  |  | LATIFA E |  |  |  |  |  |  |  | 12-052 | 13-002 |  | 13-015 | PR | 14-001 | PE |  |  |  |  |  |  |  | 13-010 |
| 24264465 | Survey (as found location) LTCC positions |  | 3d | 2015-05-20 | 2015-05-22 | 24264460 | 132d | 0d | 8/5 M-F w/JLAB Holidays ReBaseline | MECH TECH [72 h] | 3,407.04 | 24264465 | 0 |  | ELOUADRHIRI L | 1 | 1 |  |  | H | LATIFA E |  |  |  |  |  |  |  | 12-052 | 13-002 |  | 13-015 | PR | 14-001 | PE |  |  |  |  |  |  |  |  |
| 24264765 | Pump VJ, leak and pressure test |  | 10d | 2015-05-21 | 2015-06-05 | 24264762H, 24264760 | 25d | 0d | 8/5 M-F w/JLAB Holidays ReBaseline | MECH TECH [80 h] | 3,785.6 | 24264765 | 0 |  | ELOUADRHIRI L | 1 | 1 |  |  |  | LATIFA E |  |  |  |  |  |  |  | 12-052 | 13-002 |  | 13-015 | PR | 14-001 | PE |  |  |  |  |  |  |  | 13-010 |

Notes:
- 24264920: Steps: Conceptual design; 3D model; Drawings
- 24264868: Steps: Design HTCC gas system; Install gas system
- 24264350: Steps: Move 1 moeller quad magnet; Move table
- 24264460: Steps: Transport and Install LTCC sector 1; Transport and Install LTCC sector 2; Transport and Install LTCC sector 3; Transport and Install LTCC sector 4; Transport and Install LTCC sector 5; Transport and Install LTCC sector 6

| ID | Activity | Type | Duration | Start | Finish | Predecessors | Total float | Free float | Calendar | Resources | Cost | Original Activity ID Rebaseline | MONTHLY EV COST | RESP - Responsibility | STRT%COMP for CM EVM | FNSH%COMP for CM EVM | EVMS Reporting Codes | CAM RESPONSIBLE | CR 12-052 | CR 13-002 | BOE Labor | CR 13-015 | Post Rebaseline | CR 14-001 | CR 13-010 | PHAS - Project Phase | CR 09-030 | CR 09-030 Repair | CR 11-026 | CR 11-035 | CR 12-024 | Remaining Material Cost Based on % Compl | Claimed Material Cost Based on % Complet | Initial Claimed Material Calc | Claimed Material Divider | Activities with Steps | BOE Procurement | BOE Expenses | SC Magnet Dates | CR 08-016 | CR 09-012 | LOE % Pre Calc | LOE % | LOE Divider | LOE Multiplier | CR 11-022 | CR 12-007 | CR 10-005 |
| --- | --- | --- | --- | --- | --- | --- | --- | --- | --- | --- | --- | --- | --- | --- | --- | --- | --- | --- | --- | --- | --- | --- | --- | --- | --- | --- | --- | --- | --- | --- | --- | --- | --- | --- | --- | --- | --- | --- | --- | --- | --- | --- | --- | --- | --- | --- | --- | --- |
| 24264470 | Cable/test/repair LTCC's |  | 6d | 2015-05-22 | 2015-06-02 | 24264465 FS-1d | 142d | 235d | 8/5 M-F w/JLAB Holidays ReBaseline | MECH TECH [96 h]; SCIENTIST [48 h] | 8,151.36 | 24264470 | 0 | ELOUADRHIRI L | 1 | 1 | H | LATIFA E | 12-052 | 13-002 | PE | 13-015 | PR | 14-001 |  |  |  |  |  |  |  |  |  |  |  |  |  |  |  |  |  |  |  |  |  |  |  |  |
| 24264490 | Transport and Install TOF Panel 2 and align relative to panel 1a |  | 6d | 2015-05-26 | 2015-06-03 | 24264465, 24264460, 24264045M, 24264065M | 132d | 0d | 8/5 M-F w/JLAB Holidays ReBaseline | MECH TECH [192 h] | 9,085.44 | 24264490 | 0 | ELOUADRHIRI L | 1 | 1 | H | LATIFA E | 12-052 | 13-002 | PE | 13-015 | PR | 14-001 |  |  |  |  |  |  |  |  |  |  |  |  |  |  |  |  |  |  |  |  |  |  |  |  |
| 24264495 | Final Survey TOF panel 2's Positions |  | 3d | 2015-06-04 | 2015-06-08 | 24264490 | 132d | 0d | 8/5 M-F w/JLAB Holidays ReBaseline | MECH TECH [72 h] | 3,407.04 | 24264495 | 0 | ELOUADRHIRI L | 1 | 1 | H | LATIFA E | 12-052 | 13-002 | PE | 13-015 | PR | 14-001 |  |  |  |  |  |  |  |  |  |  |  |  |  |  |  |  |  |  |  |  |  |  |  |  |
| 24264770 | Install mounting adapters for drift chambers |  | 10d | 2015-06-08 | 2015-06-19 | 24264755, 24264765, 24264900 | 25d | 0d | 8/5 M-F w/JLAB Holidays ReBaseline | MECH TECH [327.6 h]; MECH ENG [120 h] | 24,462.43 | 24264770 | 0 | ELOUADRHIRI L | 1 | 1 |  | LATIFA E | 12-052 | 13-002 | PE | 13-015 | PR | 14-001 | 13-010 |  |  |  |  |  |  |  |  |  |  |  |  |  |  |  |  |  |  |  |  |  |  |  |
| 24264500 | Cable/test/repair Panel 2 TOFs |  | 6d | 2015-06-09 | 2015-06-16 | 24264490 FS-5d, 24264495 | 132d | 225d | 8/5 M-F w/JLAB Holidays ReBaseline | MECH TECH [96 h]; SCIENTIST [48 h] | 8,151.36 | 24264500 | 0 | ELOUADRHIRI L | 1 | 1 | H | LATIFA E | 12-052 | 13-002 | PE | 13-015 | PR | 14-001 |  |  |  |  |  |  |  |  |  |  |  |  |  |  |  |  |  |  |  |  |  |  |  |  |
| 24264080M | HTCC Ready for Installation | milestone | 0d | 2015-06-22 | 2015-06-22 | 242241650M | 114d | 86d | 8/5 M-F w/JLAB Holidays ReBaseline |  |  | 24264080M | 0 | ELOUADRHIRI L | 1 | 1 | M | LATIFA E | 12-052 | 13-002 |  | 13-015 | PR |  |  |  |  |  |  |  |  |  |  |  |  |  |  |  |  |  |  |  |  |  |  |  |  |  |
| 24264775 | Connect instrumentation and Leads |  | 5d | 2015-06-22 | 2015-06-26 | 242771035, 24264760, 24264770 | 25d | 0d | 8/5 M-F w/JLAB Holidays ReBaseline | ELEC TECH [216 h]; MECH ENG [40 h]; MECH TECH [100 h]; ELEC ENG [40 h] | 20,873.84 | 24264775 | 0 | ELOUADRHIRI L | 1 | 1 |  | LATIFA E | 12-052 | 13-002 | PE | 13-015 | PR | 14-001 | 13-010 |  |  |  |  |  |  |  |  |  |  |  |  |  |  |  |  |  |  |  |  |  |  |  |
| 24264780 | Connect Torus cryo lines |  | 2d | 2015-06-29 | 2015-06-30 | 24264770, 24264775 | 25d | 0d | 8/5 M-F w/JLAB Holidays ReBaseline | MECH ENG [40 h]; MECH TECH [132 h] | 9,233.04 | 24264780 | 0 | ELOUADRHIRI L | 1 | 1 |  | LATIFA E | 12-052 | 13-002 | PE | 13-015 | PR | 14-001 | 13-010 |  |  |  |  |  |  |  |  |  |  |  |  |  |  |  |  |  |  |  |  |  |  |  |
| 24264886 | Install DC HV/LV Racks and cable trays |  | 22d | 2015-07-15 | 2015-08-13 | 24264884 FS-70d | 50d | 25d | 8/5 M-F w/JLAB Holidays ReBaseline | MECH TECH [192 h] | 9,085.44 | 24264886 | 0 | ELOUADRHIRI L | 1 | 1 | H | LATIFA E | 12-052 | 13-002 | PE | 13-015 | PR | 14-001 |  | IN | 09-030 | 09-030 | 11-026 | 11 -035 | 12-024 |  |  |  |  |  |  |  |  |  |  |  |  |  |  |  |  |  |
| 24264015M | CTOF Ready for Installation | milestone | 0d | 2015-08-05 | 2015-08-05 | 242231470M | 45d | 138d | 8/5 M-F w/JLAB Holidays ReBaseline |  |  | 24264015M | 0 | ELOUADRHIRI L | 1 | 1 | M | LATIFA E | 12-052 | 13-002 |  | 13-015 | PR |  |  |  |  |  |  |  |  |  |  |  |  |  |  |  |  |  |  |  |  |  |  |  |  |  |
| 24264882 | Install DC signal cable trays and gas lines |  | 35d | 2015-09-02 | 2015-10-21 | 24264915 FS+169d | 50d | 0d | 8/5 M-F w/JLAB Holidays ReBaseline | MECH TECH [640 h]; PROCUREMENT<$50K 60; PLABOR | 54,523.19 | 24264882 | 0 | ELOUADRHIRI L | 1 | 1 | S | LATIFA E | 12-052 | 13-002 | PE | 13-015 | PR | 14-001 |  | IN | 09-030 | 09-030 | 11-026 | 11 -035 | 12-024 | 4680.02 | 0 | 0 | 100 | ST | PE | PE |  |  |  |  |  |  |  |  |  |  |
| 24264884 | Route DC Signal Cables |  | 35d | 2015-09-02 | 2015-10-21 | 24264882 FS-35d | 50d | 0d | 8/5 M-F w/JLAB Holidays ReBaseline | MECH TECH [480 h] | 22,713.6 | 24264884 | 0 | ELOUADRHIRI L | 1 | 1 | S | LATIFA E | 12-052 | 13-002 | PE | 13-015 | PR | 14-001 |  | IN | 09-030 | 09-030 | 11-026 | 11 -035 | 12-024 |  |  |  |  | ST |  |  |  |  |  |  |  |  |  |  |  |  |
| 24264788M | Torus Assembled and Tested | milestone | 0d | 2015-09-21 | 2015-09-21 | 242743125, 242743120, 28226015, 242711.2005, 242743115 | 25d | 0d | 8/5 M-F w/JLAB Holidays ReBaseline |  |  | 24264788M | 0 | ELOUADRHIRI L | 1 | 1 | M | LATIFA E | 12-052 | 13-002 |  | 13-015 | PR |  | 13-010 |  | 09-030 | 09-030 | 11-026 | 11 -035 | 12-024 |  |  |  |  |  |  |  | Y |  |  |  |  |  |  |  |  |  |
| 24264960M | Start Installation of Drift Chambers | milestone | 0d | 2015-09-21 | 2015-09-21 | 24264935, 24264900, 24264930, 3P-26M, 24264788M, 24264770, 24264890, 24264880, 24264765, 24264025M, 24264886 | 25d | 0d | 8/5 M-F w/JLAB Holidays ReBaseline |  |  | 24264960M | 0 | ELOUADRHIRI L | 1 | 1 | M | LATIFA E | 12-052 | 13-002 |  | 13-015 | PR |  | 13-010 | IN | 09-030 | 09-030 | 11-026 | 11 -035 | 12-024 |  |  |  |  |  |  |  |  | 08-016 | 09-012 |  |  |  |  |  |  |  |
| 24264965 | Install Region 2 Drift Chamber |  | 10d | 2015-09-29 | 2015-10-12 | 24264025M, 28226010, 28226015, 24264960M FS+6d | 25d | 0d | 8/5 M-F w/JLAB Holidays ReBaseline | MECH TECH [544 h] | 25,742.08 | 24264965 | 0 | ELOUADRHIRI L | 1 | 1 | S | LATIFA E | 12-052 | 13-002 | PE | 13-015 | PR | 14-001 | 13-010 |  |  |  |  |  |  |  |  |  |  | ST |  |  |  |  |  |  |  |  |  |  |  |  |
| 24264006LOE | Installation Engineering Oversight FY16 |  | 77d | 2015-09-30 | 2016-01-28 | 24264005LOE | 420d | 575d | 8/5 M-F w/JLAB Holidays ReBaseline | SR STAFF [930 h]; MECH ENG [530 h] | 151,472.7 | 24264006LOE | 0 | ELOUADRHIRI L | 1 | 1 | E | LATIFA E |  |  | PE | 13-015 | PR | 14-001 |  |  | 09-030 | 09-030 | 11-026 | 11 -035 |  |  |  |  |  |  |  |  |  |  |  | 100 | 0 | 100 | 100 |  |  |  |
| 24264798M | Start Installation of Solenoid | milestone | 0d | 2015-10-05 | 2015-10-05 | 24264794, 2-35M FS+23d, 24264797, 24272075k FS-10d, 242781020, 24264791, 24264515 | -93d | 0d | 8/5 M-F w/JLAB Holidays ReBaseline |  |  | 24264798M | 0 | ELOUADRHIRI L | 1 | 1 | M | LATIFA E | 12-052 | 13-002 |  | 13-015 | PR |  |  | IN | 09-030 | 09-030 | 11-026 | 11 -035 | 12-024 |  |  |  |  |  |  |  |  | 08-016 | 09-012 |  |  |  |  |  |  |  |
| 24264800 | Receive and inspect solenoid magnet from Vendor |  | 3d | 2015-10-05 | 2015-10-07 | 24264798M | -93d | 0d | 8/5 M-F w/JLAB Holidays ReBaseline | MECH TECH [160 h]; MECH ENG [80 h]; ELEC TECH [80 h] | 17,304 | 24264800 | 0 | ELOUADRHIRI L | 1 | 1 | S | LATIFA E | 12-052 | 13-002 | PE | 13-015 | PR | 14-001 |  | IN | 09-030 | 09-030 | 11-026 | 11 -035 | 12-024 |  |  |  |  |  |  |  |  |  |  |  |  |  |  | 11-022 |  |  |
| 24264805 | Install Solenoid cart |  | 1d | 2015-10-05 | 2015-10-05 | 24264800 FS-10d, 24264794a, 24264798M, 24264797 | -91d | 2d | 8/5 M-F w/JLAB Holidays ReBaseline | MECH TECH [32 h] | 1,514.24 | 24264805 | 0 | ELOUADRHIRI L | 1 | 1 | H | LATIFA E | 12-052 | 13-002 | PE | 13-015 | PR | 14-001 |  | IN | 09-030 | 09-030 | 11-026 | 11 -035 | 12-024 |  |  |  |  |  |  |  |  |  |  |  |  |  |  | 11-022 |  |  |
| 24264970 | Survey/align R2 Drift chambers |  | 5d | 2015-10-06 | 2015-10-12 | 24264965 FS-5d | 25d | 0d | 8/5 M-F w/JLAB Holidays ReBaseline | MECH TECH [240 h] | 11,356.8 | 24264970 | 0 | ELOUADRHIRI L | 1 | 1 | S | LATIFA E | 12-052 | 13-002 | PE | 13-015 | PR | 14-001 | 13-010 |  |  |  |  |  |  |  |  |  |  | ST |  |  |  |  |  |  |  |  |  |  |  |  |
| 24264810 | Assemble Solenoid and Piping |  | 30d | 2015-10-08 | 2015-11-18 | 24264800, 24264805 | -93d | 0d | 8/5 M-F w/JLAB Holidays ReBaseline | PLABOR; MECH TECH [240 h] | 20,147.08 | 24264810 | 0 | ELOUADRHIRI L | 1 | 1 | S | LATIFA E | 12-052 | 13-002 | PE | 13-015 | PR | 14-001 |  |  |  |  |  | 11 -035 | 12-024 |  |  |  |  |  |  | PE |  |  |  |  |  |  |  |  |  |  |
| 24264975 | Install Region 1 Drift Chamber |  | 10d | 2015-10-12 | 2015-10-23 | 28226015, 24264030M, 28226010, 24264960M, 24264970 FS-1d | 25d | 0d | 8/5 M-F w/JLAB Holidays ReBaseline | MECH TECH [544 h] | 25,742.08 | 24264975 | 0 | ELOUADRHIRI L | 1 | 1 | S | LATIFA E | 12-052 | 13-002 | PE | 13-015 | PR | 14-001 | 13-010 |  |  |  |  |  |  |  |  |  |  | ST |  |  |  |  |  |  |  |  |  |  |  |  |
| 24264980 | Survey/align R1 Drift chambers |  | 5d | 2015-10-15 | 2015-10-21 | 24264975 FS-7d | 25d | 0d | 8/5 M-F w/JLAB Holidays ReBaseline | MECH TECH [240 h] | 11,356.8 | 24264980 | 0 | ELOUADRHIRI L | 1 | 1 | S | LATIFA E | 12-052 | 13-002 | PE | 13-015 | PR | 14-001 | 13-010 |  |  |  |  |  |  |  |  |  |  | ST |  |  |  |  |  |  |  |  |  |  |  |  |
| 24264985 | Install Region 3 Drift Chamber |  | 10d | 2015-10-21 | 2015-11-03 | 24264020M, 24264980 FS-1d, 28226010, 28226015, 24264960M | 25d | 0d | 8/5 M-F w/JLAB Holidays ReBaseline | MECH TECH [544 h] | 25,742.08 | 24264985 | 0 | ELOUADRHIRI L | 1 | 1 | S | LATIFA E | 12-052 | 13-002 | PE | 13-015 | PR | 14-001 | 13-010 |  |  |  |  |  |  |  |  |  |  | ST |  |  |  |  |  |  |  |  |  |  |  |  |
| 24264870 | Rig and Transport HTCC to Hall |  | 2d | 2015-10-22 | 2015-10-23 | 24264080M, 24264980 | 28d | 0d | 8/5 M-F w/JLAB Holidays ReBaseline | MECH TECH [40 h] | 1,892.8 | 24264870 | 0 | ELOUADRHIRI L | 1 | 1 | H | LATIFA E | 12-052 | 13-002 | PE | 13-015 | PR | 14-001 | 13-010 | IN | 09-030 | 09-030 | 11-026 | 11 -035 | 12-024 |  |  |  |  |  |  |  |  |  |  |  |  |  |  | 11-022 | 12-007 |  |
| 24264872 | Install HTCC cart |  | 4d | 2015-10-26 | 2015-10-29 | 24264870, 24264160, 24264868 | 28d | 42d | 8/5 M-F w/JLAB Holidays ReBaseline | MECH TECH [20 h] | 946.4 | 24264872 | 0 | ELOUADRHIRI L | 1 | 1 | H | LATIFA E | 12-052 | 13-002 | PE | 13-015 | PR | 14-001 | 13-010 |  |  |  |  | 11 -035 | 12-024 |  |  |  |  |  |  |  |  |  |  |  |  |  |  |  | 12-007 |  |
| 24264990 | Survey/align R3 Drift chambers |  | 5d | 2015-10-27 | 2015-11-02 | 24264985 FS-6d | 25d | 0d | 8/5 M-F w/JLAB Holidays ReBaseline | MECH TECH [240 h] | 11,356.8 | 24264990 | 0 | ELOUADRHIRI L | 1 | 1 | S | LATIFA E | 12-052 | 13-002 | PE | 13-015 | PR | 14-001 | 13-010 |  |  |  |  |  |  |  |  |  |  | ST |  |  |  |  |  |  |  |  |  |  |  |  |
| 24264995 | Connect / Cable Drift Chambers |  | 10d | 2015-11-03 | 2015-11-16 | 24264990 | 25d | 118d | 8/5 M-F w/JLAB Holidays ReBaseline | ELEC TECH [80 h]; SCIENTIST [80 h] | 9,773.6 | 24264995 | 0 | ELOUADRHIRI L | 1 | 1 | H | LATIFA E | 12-052 | 13-002 | PE | 13-015 | PR | 14-001 | 13-010 |  |  |  |  |  |  |  |  |  |  |  |  |  |  |  |  |  |  |  |  |  |  |  |
| 24264815 | Solenoid instrumentation and current leads |  | 10d | 2015-11-18 | 2015-12-03 | 24264810 FS-1d, 242710.1030, 242791060 FS-1d | -93d | 0d | 8/5 M-F w/JLAB Holidays ReBaseline | ELEC TECH [160 h] | 7,518.4 | 24264815 | 0 | ELOUADRHIRI L | 1 | 1 | H | LATIFA E | 12-052 | 13-002 | PE | 13-015 | PR | 14-001 |  |  |  |  |  | 11 -035 | 12-024 |  |  |  |  |  |  |  |  |  |  |  |  |  |  |  |  |  |
| 24264820 | Align Solenoid |  | 2d | 2015-12-03 | 2015-12-04 | 24264815 FS-1d | -93d | 0d | 8/5 M-F w/JLAB Holidays ReBaseline | MECH TECH [16 h] | 757.12 | 24264820 | 0 | ELOUADRHIRI L | 1 | 1 | H | LATIFA E | 12-052 | 13-002 | PE | 13-015 | PR | 14-001 |  |  |  |  |  | 11 -035 | 12-024 |  |  |  |  |  |  |  |  |  |  |  |  |  |  |  |  |  |
| 24264825 | Connect Solenoid Cryo lines |  | 20d | 2015-12-07 | 2016-01-12 | 24264820 | -93d | 0d | 8/5 M-F w/JLAB Holidays ReBaseline |  |  | 24264825 | 0 | ELOUADRHIRI L | 1 | 1 | Z | LATIFA E | 12-052 | 13-002 |  | 13-015 | PR |  |  |  |  |  |  |  |  |  |  |  |  |  |  |  |  |  |  |  |  |  |  |  |  |  |
| 24264874 | Install HTCC |  | 2d | 2016-01-11 | 2016-01-12 | 28226020 FS-20d, 24264872 | -14d | 0d | 8/5 M-F w/JLAB Holidays ReBaseline | MECH TECH [120 h] | 5,678.4 | 24264874 | 0 | ELOUADRHIRI L | 1 | 1 | H | LATIFA E | 12-052 | 13-002 | PE | 13-015 | PR | 14-001 | 13-010 |  |  |  |  | 11 -035 | 12-024 |  |  |  |  |  |  |  |  |  |  |  |  |  |  |  | 12-007 |  |
| 24264876 | HTCC verify mirror alignment and align detector to beam |  | 3d | 2016-01-13 | 2016-01-15 | 24264874 | -14d | 0d | 8/5 M-F w/JLAB Holidays ReBaseline | MECH TECH [48 h]; SCIENTIST [48 h] | 5,880 | 24264876 | 0 | ELOUADRHIRI L | 1 | 1 | H | LATIFA E | 12-052 | 13-002 | PE | 13-015 | PR | 14-001 | 13-010 |  |  |  |  | 11 -035 | 12-024 |  |  |  |  |  |  |  |  |  |  |  |  |  |  |  | 12-007 |  |
| 24264878 | Cable HTCC |  | 4d | 2016-01-19 | 2016-01-22 | 24264876 | -14d | 79d | 8/5 M-F w/JLAB Holidays ReBaseline | MECH TECH [32 h] | 1,514.24 | 24264878 | 0 | ELOUADRHIRI L | 1 | 1 | H | LATIFA E | 12-052 | 13-002 | PE | 13-015 | PR | 14-001 | 13-010 |  |  |  |  | 11 -035 | 12-024 |  |  |  |  |  |  |  |  |  |  |  |  |  |  |  | 12-007 |  |
| 24264845 | Mount, assemble and cable CTOF system |  | 25d | 2016-03-01 | 2016-04-04 | 28226025, 24264805, 24264015M | -93d | 0d | 8/5 M-F w/JLAB Holidays ReBaseline | SCIENTIST [80 h]; MECH TECH [320 h] | 21,156.8 | 24264845 | 0 | ELOUADRHIRI L | 1 | 1 | S | LATIFA E | 12-052 | 13-002 | PE | 13-015 | PR | 14-001 | 13-010 | IN | 09-030 | 09-030 | 11-026 | 11 -035 | 12-024 |  |  |  |  | ST |  |  |  |  |  |  |  |  |  | 11-022 |  | 10-005 |
| 24264850 | Align CTOF |  | 5d | 2016-04-05 | 2016-04-11 | 24264845 | -93d | 0d | 8/5 M-F w/JLAB Holidays ReBaseline | MECH TECH [48 h] | 2,271.36 | 24264850 | 0 | ELOUADRHIRI L | 1 | 1 | H | LATIFA E | 12-052 | 13-002 | PE | 13-015 | PR | 14-001 | 13-010 |  |  |  |  | 11 -035 | 12-024 |  |  |  |  |  |  |  |  |  |  |  |  |  |  |  |  |  |
| 24264855 | Mount, cable and check SVT system |  | 15d | 2016-04-11 | 2016-04-29 | 24264850 FS-1d, 24264010M | -93d | 0d | 8/5 M-F w/JLAB Holidays ReBaseline | MECH TECH [320 h]; SCIENTIST [80 h] | 21,156.8 | 24264855 | 0 | ELOUADRHIRI L | 1 | 1 | S | LATIFA E | 12-052 | 13-002 | PE | 13-015 | PR | 14-001 | 13-010 |  |  |  |  | 11 -035 | 12-024 |  |  |  |  | ST |  |  |  |  |  |  |  |  |  |  |  |  |
| 24264860 | Align SVT |  | 10d | 2016-04-29 | 2016-05-12 | 24264855 FS-1d | -93d | 0d | 8/5 M-F w/JLAB Holidays ReBaseline | MECH TECH [48 h] | 2,271.36 | 24264860 | 0 | ELOUADRHIRI L | 1 | 1 | H | LATIFA E | 12-052 | 13-002 | PE | 13-015 | PR | 14-001 | 13-010 |  |  |  |  | 11 -035 | 12-024 |  |  |  |  |  |  |  |  |  |  |  |  |  |  |  |  |  |
| 24264860M | Central Detector Ready | milestone | 0d | 2016-05-12 | 2016-05-12 | 24264850, 24264125, 24264860 | -93d | 0d | 8/5 M-F w/JLAB Holidays ReBaseline |  |  | 24264860M | 0 | ELOUADRHIRI L | 1 | 1 | M | LATIFA E | 12-052 | 13-002 |  | 13-015 | PR |  | 13-010 |  |  |  |  |  |  |  |  |  |  |  |  |  |  |  |  |  |  |  |  |  |  |  |

Notes:
- 24264882: Steps: Connect cables to R1 cable trays; Install R1 cable trays; Connect cables to R3 cable trays; Install R3 cable trays; Install cable trays on Torus; Install gas lines
- 24264884: Steps: Route cables for region 1; Route cables for region 2; Route cables for region 3
- 24264965: Steps: Install Region 2 Drift Chamber Sector 1; Install Region 2 Drift Chamber Sector 2; Install Region 2 Drift Chamber Sector 3; Install Region 2 Drift Chamber Sector 4; Install Region 2 Drift Chamber Sector 5; Install Region 2 Drift Chamber Sector 6
- 24264970: Steps: Survey/align R2 Drift chambers Sector 1; Survey/align R2 Drift chambers Sector 2; Survey/align R2 Drift chambers Sector 3; Survey/align R2 Drift chambers Sector 4; Survey/align R2 Drift chambers Sector 5; Survey/align R2 Drift chambers Sector 6
- 24264975: Steps: Install Region 1 Drift Chamber Sector 1; Install Region 1 Drift Chamber Sector 2; Install Region 1 Drift Chamber Sector 3; Install Region 1 Drift Chamber Sector 4; Install Region 1 Drift Chamber Sector 5; Install Region 1 Drift Chamber Sector 6
- 24264980: Steps: Survey/align R1 Drift chambers Sector 1; Survey/align R1 Drift chambers Sector 2; Survey/align R1 Drift chambers Sector 3; Survey/align R1 Drift chambers Sector 4; Survey/align R1 Drift chambers Sector 5; Survey/align R1 Drift chambers Sector 6
- 24264985: Steps: Install Region 3 Drift Chamber Sector 1; Install Region 3 Drift Chamber Sector 2; Install Region 3 Drift Chamber Sector 3; Install Region 3 Drift Chamber Sector 4; Install Region 3 Drift Chamber Sector 5; Install Region 3 Drift Chamber Sector 6
- 24264990: Steps: Survey/align R3 Drift chambers Sector 1; Survey/align R3 Drift chambers Sector 2; Survey/align R3 Drift chambers Sector 3; Survey/align R3 Drift chambers Sector 4; Survey/align R3 Drift chambers Sector 5; Survey/align R3 Drift chambers Sector 6
- 24264845: Steps: Install CTOF support structure to solenoid; Install 48 counters; Install 96 magnetic shields; Cable detector
- 24264855: Steps: Install SVT cart; Install SVT electronics; Place SVT on cart

| ID | WBS | Activity | Type | Duration | Start | Finish | Predecessors | Complete | Remaining | Planned start | Planned finish | Total float | Free float | Calendar | Resources | Cost | Actual cost | Remaining Material Cost Based on % Compl | Claimed Material Cost Based on % Complet | Initial Claimed Material Calc | Claimed Material Divider | Calculated Remaining Total Cost | MONTHLY EV COST | RESP - Responsibility | STRT%COMP for CM EVM | FNSH%COMP for CM EVM | EVMS Reporting Codes | CAM RESPONSIBLE | 12 GEV MAJOR PROCUREMENT CATAGORY | CR 12-011 | CR 12-024 | LOE % Pre Calc | LOE % | LOE Divider | LOE Multiplier | CR 13-005 | CR 12-042 | MARCH!!! | Activities with Steps | CR 13-002 | ReBaseline Actuals Adjustment | Original Activity ID Rebaseline | BOE Procurement | CR 13-015 | Post Rebaseline | Obligated Prior to Rebaseline | PRIOR MONTH EV COST | SC Magnet Dates | BOE Labor | CR 14-001 |
| --- | --- | --- | --- | --- | --- | --- | --- | --- | --- | --- | --- | --- | --- | --- | --- | --- | --- | --- | --- | --- | --- | --- | --- | --- | --- | --- | --- | --- | --- | --- | --- | --- | --- | --- | --- | --- | --- | --- | --- | --- | --- | --- | --- | --- | --- | --- | --- | --- | --- | --- |
|  | 7 | **1.4.2.7 HALL B MAGNETS** |  |  | 2011-12-03 | 2015-11-02 |  |  |  |  |  |  |  |  |  |  |  |  |  |  |  |  |  |  |  |  |  |  |  |  |  |  |  |  |  |  |  |  |  |  |  |  |  |  |  |  |  |  |  |  |
|  | 1 | **1.4.2.7.1 TOROIDAL MAGNET NEW VENDOR** |  |  | 2011-12-03 | 2014-10-31 |  |  |  |  |  |  |  |  |  |  |  |  |  |  |  |  |  |  |  |  |  |  |  |  |  |  |  |  |  |  |  |  |  |  |  |  |  |  |  |  |  |  |  |  |
| 14271000 |  | Procure Replacement Copper |  | 11d | 2011-12-03 A | 2011-12-19 A | 9-120M FS+41d | 100% |  | 2011-12-05 | 2011-12-19 |  |  |  | PROCUREMENT<$50K 60 | 20,000 |  | 0 | 20000 | 2000000 | 100 | 0 | 20000 | ELOUADRHIRI L | 1 | 1 | D | LATIFA E | 4211 | 12-011 | 12-024F |  |  |  |  |  |  |  |  |  |  |  |  |  |  |  |  |  |  |  |
| 14271005 |  | JLab Design and Support Labor FY12 |  | 84d | 2012-06-01 A | 2012-09-28 A | 9-120M FS+163d | 100% |  |  |  |  |  |  | MECH ENG [1273.33 h] | 89,285.9 | 89,285.9 |  |  |  |  | 0 | 89285.8996 | ELOUADRHIRI L | 1 | 1 | E | LATIFA E | 4211 | 12-011 | 12-024 | 22.61904761 | 77.38095238 | 100 | 100 | 13-005F |  |  |  |  |  |  |  |  |  |  |  |  |  |  |
| 14271015 |  | FNAL: Kickoff Meeting |  | 2d | 2012-06-01 A | 2012-06-05 A | 9-120M FS+163d | 100% |  |  |  |  |  |  | PROCUREMENT<$50K 60 NO ESCALATION | 2,416 |  | 0 | 2416 | 241600 | 100 | 0 | 2416 | ELOUADRHIRI L | 1 | 1 | P | LATIFA E | 4211 |  | 12-024 |  |  |  |  |  | 12-042 |  |  |  |  |  |  |  |  |  |  |  |  |  |
| 14271020 |  | FNAL: Discussions on Manufacturing possibilities |  | 10d | 2012-06-01 A | 2012-06-17 A | 14273010 FS-86d, 14271015 FS-10d, 14273014B FS-135d, 14273010K FS-270d, 14273012 FS-270d | 100% |  | 2012-06-01 | 2012-06-15 |  |  |  | PROCUREMENT<$50K 60 NO ESCALATION | 24,160 |  | 0 | 24160 | 2416000 | 100 | 0 | 24160 | ELOUADRHIRI L | 1 | 1 | P | LATIFA E | 4211 |  | 12-024 |  |  |  |  |  | 12-042 |  |  |  |  |  |  |  |  |  |  |  |  |  |
| 14271025 |  | FNAL: Acceptance of Proposal for fabrication |  | 51d | 2012-06-01 A | 2012-08-13 A | 14271020 FS-11d | 100% |  |  |  |  |  |  | PROCUREMENT<$50K 60 NO ESCALATION | 2,416 |  | 0 | 2416 | 241600 | 100 | 0 | 2416 | ELOUADRHIRI L | 1 | 1 | P | LATIFA E | 4211 |  | 12-024 |  |  |  |  |  | 12-042 |  |  |  |  |  |  |  |  |  |  |  |  |  |
| 14271025A |  | FNAL: Overview of Wang NMR CCM Design |  | 56d | 2012-06-01 A | 2012-08-20 A | 14271025 FS-12d | 100% |  |  |  |  |  |  | PROCUREMENT<$50K 60 NO ESCALATION; PROCUREMENT>$50K 69 NO ESCALATION | 26,576 |  | 0 | 26576 | 2657600 | 100 | 0 | 26576 | ELOUADRHIRI L | 1 | 1 | P | LATIFA E | 4211 |  |  |  |  |  |  |  | 12-042 |  |  |  |  |  |  |  |  |  |  |  |  |  |
| 14271025B |  | FNAL: Develop CCM fabrication and QA/QC plans |  | 148d | 2012-06-01 A | 2013-02-18 A | 14271025A FS-12d | 100% |  | 2012-06-01 | 2013-01-08 |  |  |  | PROCUREMENT>$50K 69 NO ESCALATION | 48,320 |  | 0 | 48320 | 4832000 | 100 | 0 | 48320 | ELOUADRHIRI L | 1 | 1 | D | LATIFA E | 4211 |  |  |  |  |  |  |  | 12-042 | XX |  |  |  |  |  |  |  |  |  |  |  |  |
| 14271025C |  | FNAL: Design of CCM Tooling |  | 182d | 2012-06-01 A | 2013-02-18 A | 14271025B FS-33d | 100% |  | 2012-06-01 | 2013-02-27 |  |  |  | PROCUREMENT>$50K 69 NO ESCALATION | 106,304 |  | 0 | 106304 | 10630400 | 100 | 0 | 106304 | ELOUADRHIRI L | 1 | 1 | D | LATIFA E | 4211 |  |  |  |  |  |  |  | 12-042 |  |  |  |  |  |  |  |  |  |  |  |  |  |
| 14271025D |  | FNAL: Tooling Installation at FNAL |  | 224d | 2012-06-01 A | 2013-08-30 A | 14271025C FS-65d, 14271026 FS-105d | 100% |  | 2012-06-01 | 2013-04-26 |  |  |  | PROCUREMENT>$50K 69 NO ESCALATION | 24,160 |  | 0 | 24160 | 2416000 | 100 | 3624 | 24160 | ELOUADRHIRI L | 1 | 1 | D | LATIFA E | 4211 |  |  |  |  |  |  |  | 12-042 |  |  |  |  |  |  |  |  |  |  |  |  |  |
| 14271025F |  | FNAL: Manufacturing Readiness Review |  | 213d | 2012-06-01 A | 2013-08-30 A | 14271025D FS-100d | 100% |  | 2012-06-01 | 2013-04-11 |  |  |  | PROCUREMENT>$50K 69 NO ESCALATION | 4,832 |  | 0 | 4832 | 483200 | 100 | 2416 | 4832 | ELOUADRHIRI L | 1 | 1 | D | LATIFA E | 4211 |  |  |  |  |  |  |  | 12-042 |  |  |  |  |  |  |  |  |  |  |  |  |  |
| 14271025G |  | FNAL: Prototype CCM winding and tests |  | 242d | 2012-06-01 A | 2013-08-30 A | 14271025F FS-90d | 100% |  | 2012-06-01 | 2013-05-22 |  |  |  | PROCUREMENT>$50K 69 NO ESCALATION | 144,960 |  | 0 | 144960 | 14496000 | 100 | 115968 | 144960 | ELOUADRHIRI L | 1 | 1 | D | LATIFA E | 4211 |  |  |  |  |  |  |  | 12-042 |  |  |  |  |  |  |  |  |  |  |  |  |  |
| 14271025H |  | FNAL: Update design with lessons learned from prototype |  | 285d | 2012-06-01 A | 2013-08-30 A | 14271025G FS-143d | 100% |  | 2012-06-01 | 2013-07-24 |  |  |  | PROCUREMENT>$50K 69 NO ESCALATION | 60,400 |  | 0 | 60400 | 6040000 | 100 | 60400 | 60400 | ELOUADRHIRI L | 1 | 1 | D | LATIFA E | 4211 |  |  |  |  |  |  |  | 12-042 |  |  |  |  |  |  |  |  |  |  |  |  |  |
| 14271025J |  | FNAL: Production CCM readiness review |  | 286d | 2012-06-01 A | 2013-08-30 A | 14271025H FS-164d | 100% |  | 2012-06-01 | 2013-07-25 |  |  |  | PROCUREMENT>$50K 69 NO ESCALATION | 2,416 |  | 0 | 2416 | 241600 | 100 | 2416 | 2416 | ELOUADRHIRI L | 1 | 1 | D | LATIFA E | 4211 |  |  |  |  |  |  |  | 12-042 |  |  |  |  |  |  |  |  |  |  |  |  |  |
| 14271025K |  | FNAL: Production final CCM#1 and test |  | 312d | 2012-06-01 A | 2013-08-30 A | 14271025J FS-164d | 100% |  |  |  |  |  |  | PROCUREMENT>$50K 69 NO ESCALATION | 114,336 |  | 0 | 114336 | 11433600 | 100 | 114336 | 114336 | ELOUADRHIRI L | 1 | 1 | D | LATIFA E | 4211 |  |  |  |  |  |  |  | 12-042 |  |  |  |  |  |  |  |  |  |  |  |  |  |
| 14271025L |  | FNAL: Production final CCM#2 and test |  | 343d | 2012-06-01 A | 2013-08-30 A | 14271025K FS-226d | 100% |  | 2012-06-01 | 2013-10-15 |  |  |  | PROCUREMENT>$50K 69 NO ESCALATION | 104,898 |  | 0 | 104898 | 10489800 | 100 | 104898 | 104898 | ELOUADRHIRI L | 1 | 1 | D | LATIFA E | 4211 |  |  |  |  |  |  |  | 12-042 |  |  |  |  |  |  |  |  |  |  |  |  |  |
| 14271025N |  | FNAL: Production final CCM#3 and test |  | 379d | 2012-06-01 A | 2013-08-30 A | 14271025L FS-248d | 100% |  | 2012-06-01 | 2013-12-06 |  |  |  | PROCUREMENT>$50K 69 NO ESCALATION | 102,426 |  | 0 | 102426 | 10242600 | 100 | 102426 | 102426 | ELOUADRHIRI L | 1 | 1 | D | LATIFA E | 4211 |  |  |  |  |  |  |  | 12-042 |  |  |  |  |  |  |  |  |  |  |  |  |  |
| 14271025P |  | FNAL: Production final CCM#4 and test |  | 394d | 2012-06-01 A | 2013-08-30 A | 14271025N FS-290d | 100% |  | 2012-06-01 | 2014-01-06 |  |  |  | PROCUREMENT>$50K 69 NO ESCALATION | 71,460 |  | 0 | 71460 | 7146000 | 100 | 71460 | 71460 | ELOUADRHIRI L | 1 | 1 | D | LATIFA E | 4211 |  |  |  |  |  |  |  | 12-042 |  |  |  |  |  |  |  |  |  |  |  |  |  |
| 14271025Q |  | FNAL: Production final CCM#5 and test |  | 413d | 2012-06-01 A | 2013-08-30 A | 14271025P FS-290d | 100% |  | 2012-06-01 | 2014-02-03 |  |  |  | PROCUREMENT>$50K 69 NO ESCALATION | 71,460 |  | 0 | 71460 | 7146000 | 100 | 71460 | 71460 | ELOUADRHIRI L | 1 | 1 | D | LATIFA E | 4211 |  |  |  |  |  |  |  | 12-042 |  |  |  |  |  |  |  |  |  |  |  |  |  |
| 14271027LOE |  | JLab support of FNAL Torus CCM effort FY12 |  | 84d | 2012-06-01 A | 2012-09-28 A | 9-120M FS+163d | 100% |  |  |  |  |  |  | MECH DES [560.07 h]; MECH ENG [560.1 h] | 66,252.78 | 66,252.78 |  |  |  |  | 0 | 66252.7839 | ELOUADRHIRI L | 1 | 1 | E | LATIFA E | 4211 |  |  | 22.61904761 | 77.38095238 | 100 | 100 | 13-005F | 12-042 |  |  |  |  |  |  |  |  |  |  |  |  |  |
| 14271010 |  | JLab Design and Support Labor FY13 Original |  | 248d | 2012-10-01 A | 2012-12-31 A | 14271005 | 100% |  | 2012-10-01 | 2013-09-30 |  |  |  | MECH ENG [587.1 h] | 42,482.56 | 42,482.56 |  |  |  |  | 0 | 42484.7268 | ELOUADRHIRI L | 1 | 1 | E | LATIFA E | 4211 | 12-011 | 12-024 | 82.66129032 | 17.33870967 | 100 | 100 | 13-005 |  |  |  |  |  |  |  |  |  |  |  |  |  |  |
| 14271028LOE |  | JLab support of FNAL Torus CCM effort FY13 Original |  | 248d | 2012-10-01 A | 2012-12-31 A | 14271027LOE | 100% |  | 2012-10-01 | 2013-09-30 |  |  |  | MECH ENG [393.4 h]; MECH DES [393.39 h] | 48,021.84 | 48,021.84 |  |  |  |  | 0 | 48021.8409 | ELOUADRHIRI L | 1 | 1 | E | LATIFA E | 4211 |  |  | 82.66129032 | 17.33870967 | 100 | 100 | 13-005 | 12-042 |  |  |  |  |  |  |  |  |  |  |  |  |  |
| 14271012 |  | JLab Design and Support Labor FY13 Revised |  | 40d | 2012-12-03 A | 2013-02-27 A | 14271010 | 100% |  | 2013-01-02 | 2013-02-28 |  |  |  | MECH ENG [2224 h]; MECH TECH [784 h]; MECH DES [1824 h]; ELEC ENG [864 h]; PLABOR | 400,986.81 | 350,461.76 |  |  |  |  | 0 | 400986.81 | ELOUADRHIRI L | 1 | 1 | S | LATIFA E | 4211 |  | 12-024 |  |  |  |  | 13-005 |  | XX | ST | 13-002F |  |  |  |  |  |  |  |  |  |  |
| 14271028LOEA |  | JLab support of FNAL Torus CCM effort FY13 Revised |  | 189d | 2013-01-02 A | 2013-08-30 A | 14271028LOE | 100% |  | 2013-02-01 | 2013-10-29 |  |  |  | MECH ENG [1180.32 h]; MECH DES [1180.32 h] | 144,592.52 | 144,081.05 |  |  |  |  | 35835.84576 | 144081.05205 | ELOUADRHIRI L | 1 | 1 | E | LATIFA E | 4211 |  | 12-024 | 10.58201058 | 89.41798941 | 100 | 100 | 13-005 |  |  |  | 13-002F |  |  |  |  |  |  |  |  |  |  |
| 14271026 |  | JLab Fabrication of Tooling |  | 70d | 2013-02-04 A | 2013-08-30 A | 9-130M FS+10d, 9-120M FS+240d | 100% |  | 2013-03-01 | 2013-06-07 |  |  |  | PROCUREMENT>$50K 69; PROCUREMENT<$50K 60; MSHOP | 328,571.4 |  | 0 | 150000 | 15000000 | 100 | 82142.85 | 328571.4 | ELOUADRHIRI L | 1 | 1 | D | LATIFA E | 4211 |  |  |  |  |  |  |  | 12-042 |  |  |  |  |  |  |  |  |  |  |  |  |  |
| 14271030 |  | Machine Shop Effort FY13 |  | 205d | 2013-03-01 A | 2013-08-30 A | 9-130M | 100% |  | 2013-04-01 | 2014-01-28 |  |  |  | MSHOP | 246,255.71 |  |  |  |  |  | 128571.4032 | 246255.71 | ELOUADRHIRI L | 1 | 1 | D | LATIFA E | 4211 | 12-011 | 12-024 |  |  |  |  |  |  |  |  |  |  |  |  |  |  |  |  |  |  |  |
| 14271040 |  | Cryostat Factory Phase 1 |  | 60d | 2013-03-01 A | 2013-08-30 A | 9-130M FS+60d | 100% |  | 2013-04-01 | 2013-06-24 |  |  |  | MECH TECH [1460.26 h]; MECH ENG [1850.95 h]; MECH DES [1347.19 h] | 267,871.07 | 267,871.07 |  |  |  |  | 166080.06991 | 267871.0805 | ELOUADRHIRI L | 1 | 1 | S | LATIFA E | 4211 | 12-011 | 12-024 |  |  |  |  |  |  |  | ST |  |  |  |  |  |  |  |  |  |  |  |
| 14271045 |  | Cryostat Factory Phase 2 |  | 128d | 2013-08-30 A | 2013-08-30 A | 14271040 | 100% |  | 2013-09-27 | 2014-04-08 |  |  |  | MECH TECH [7885.43 h]; MECH ENG [1249.39 h] | 466,205.56 | 452,031.72 |  |  |  |  | 535741.137 | 452031.723528 | ELOUADRHIRI L | 1 | 1 | S | LATIFA E | 4211 | 12-011 | 12-024 |  |  |  |  |  |  |  | ST |  |  |  |  |  |  |  |  |  |  |  |
| 14271085 |  | Re-Baseline Actuals Adjustment |  | 1d | 2013-08-30 A | 2013-08-30 A |  | 100% |  | 2013-09-03 | 2013-09-03 |  |  |  | PROCUREMENT>$50K 69 NO ESCALATION | 558,132.32 |  | 0 | 558132.32 | 55813232 | 100 |  | 558132.32 |  |  |  |  |  |  |  |  |  |  |  |  |  |  |  |  |  | ADJ |  |  |  |  |  |  |  |  |  |
| 24271665 |  | FNAL: Tooling Fabrication and Installation at FNAL Part B |  | 10d | 2013-09-03 A | 2013-10-21 A | 9-130M FS+228d | 100% |  | 2013-10-01 | 2013-10-14 |  |  | 8/5 M-F w/JLAB Holidays ReBaseline | PROCUREMENT>$50K 69 NO ESCALATION; PROCUREMENT<$50K 60 | 2,467.22 |  | 0 | 2467.22 | 246722 | 100 |  | 2467.22 | ELOUADRHIRI L | 1 | 1 | D | LATIFA E | 4211 |  |  |  |  |  |  |  | 12-042 |  |  | 13-002F |  | 24271665 | VQ | 13-015 | PR | OB |  |  |  |  |
| 24271680 |  | FNAL: Prototype CCM winding and tests |  | 35d | 2013-09-03 A | 2013-11-27 | 24271665 FS-20d, 242751020 FS-80d | 90% | 19d | 2013-10-01 | 2013-11-18 | 159d | 26d | 8/5 M-F w/JLAB Holidays ReBaseline | PROCUREMENT>$50K 69 NO ESCALATION | 35,234.21 |  | 3523.421 | 31710.789 | 3171078.9 | 100 |  | 14093.684 | ELOUADRHIRI L | 1 | 1 | D | LATIFA E | 4211 |  |  |  |  |  |  |  | 12-042 |  |  | 13-002F |  | 24271680 | VQ | 13-015 | PR | OB | 17617.105 |  |  |  |
| 24271685 |  | FNAL: Update design with lessons learned from prototype |  | 62d | 2013-09-03 A | 2013-12-04 | 24271680 FS-45d | 25% | 22d | 2013-10-01 | 2014-01-08 | 144d | 40d | 8/5 M-F w/JLAB Holidays ReBaseline | PROCUREMENT>$50K 69 NO ESCALATION | 46,566.63 |  | 34924.9725 | 11641.6575 | 1164165.75 | 100 |  | 0 | ELOUADRHIRI L | 1 | 1 | D | LATIFA E | 4211 |  |  |  |  |  |  |  | 12-042 |  |  | 13-002F |  | 24271685 | VQ | 13-015 | PR | OB | 11641.6575 |  |  |  |
| 24271690 |  | FNAL: Production CCM readiness review |  | 62d | 2013-09-03 A | 2013-12-04 | 24271685 FS-62d |  | 22d | 2013-10-01 | 2014-01-08 | 104d | 40d | 8/5 M-F w/JLAB Holidays ReBaseline | PROCUREMENT>$50K 69 NO ESCALATION | 24,835.54 |  | 24835.54 | 0 | 0 | 100 |  | 0 | ELOUADRHIRI L | 1 | 1 | D | LATIFA E | 4211 |  |  |  |  |  |  |  | 12-042 |  |  | 13-002F |  | 24271690 | VQ | 13-015 | PR | OB |  |  |  |  |
| 24271695 |  | FNAL: Production final CCM#1 and test |  | 161d | 2013-09-03 A | 2014-04-03 | 24271690 FS-62d, 242751045 FS-139d |  | 99d | 2013-10-01 | 2014-05-29 | 64d | 0d | 8/5 M-F w/JLAB Holidays ReBaseline | PROCUREMENT>$50K 69 NO ESCALATION | 133,482.97 |  | 133482.97 | 0 | 0 | 100 |  | 0 | ELOUADRHIRI L | 1 | 1 | D | LATIFA E | 4211 |  |  |  |  |  |  |  | 12-042 |  |  | 13-002F |  | 24271695 | VQ | 13-015 | PR | OB |  | Y |  |  |
| 24271725 LOE |  | Consultant Fees WS LQ |  | 267d | 2013-09-03 A | 2014-09-30 | 9-130M FS+228d | 16% | 224d | 2013-10-01 | 2014-10-28 | 304d | 397d | 8/5 M-F w/JLAB Holidays ReBaseline | PROCUREMENT<$50K 60 NO ESCALATION FY14 | 22,950 |  | 19255.05 | 3694.95 | 369495 | 100 |  | 1975.995 | ELOUADRHIRI L | 1 | 1 | E | LATIFA E | 4211 |  |  | 83.89513108 | 16.10486891 | 100 | 100 |  | 12-042 |  |  | 13-002F |  | 24271720 | VQ | 13-015 | PR | OB | 1718.955 |  |  |  |
| 24271730 |  | Existing Coil Case Storage |  | 267d | 2013-09-03 A | 2014-10-31 | 9-130M FS+228d |  | 247d | 2013-10-01 | 2014-10-28 | 281d | 374d | 8/5 M-F w/JLAB Holidays ReBaseline | PROCUREMENT<$50K 60 NO ESCALATION FY14 | 2,106 |  | 2106 | 0 | 0 | 100 |  | 0 | ELOUADRHIRI L | 1 | 1 | D | LATIFA E | 4211 |  |  |  |  |  |  |  | 12-042 |  |  | 13-002F |  | 24271720 | VQ | 13-015 | PR | OB |  |  |  |  |
| 24271730LOE |  | JLab support of FNAL Torus CCM effort FY13 |  | 20d | 2013-09-03 A | 2013-09-30 A | 9-130M FS+228d | 100% |  | 2013-10-01 | 2013-10-28 |  |  | 8/5 M-F w/JLAB Holidays ReBaseline | SR STAFF [137.58 h] | 16,553.63 | 16,041.83 |  |  |  |  |  | 0 | ELOUADRHIRI L | 1 | 1 | E | LATIFA E | 4211 |  | 12-024 |  |  | 100 | 100 | 13-005 |  |  |  | 13-002F |  | 24271730LOE |  | 13-015 | PR |  | 16041.828 |  | EJ |  |
| 24271735 |  | Contractor Training TW |  | 267d | 2013-09-03 A | 2013-10-21 A | 9-130M FS+228d | 100% |  | 2013-10-01 | 2014-10-28 |  |  | 8/5 M-F w/JLAB Holidays ReBaseline | PROCUREMENT<$50K 60 NO ESCALATION FY14 | 266.4 |  | 0 | 266.4 | 26640 | 100 |  | 266.4 | ELOUADRHIRI L | 1 | 1 | D | LATIFA E | 4211 |  |  |  |  |  |  |  | 12-042 |  |  | 13-002F |  | 24271720 | VQ | 13-015 | PR | OB |  |  |  |  |
| 24271740 |  | Additional Torus Copper Stabilizer and SSC Cable tests for Coil #7 |  | 60d | 2013-09-03 A | 2014-01-09 | 9-130M FS+228d |  | 40d | 2013-10-01 | 2014-01-06 | 96d | 20d | 8/5 M-F w/JLAB Holidays ReBaseline | PROCUREMENT<$50K 60 NO ESCALATION FY14 | 24,035 |  | 24035 | 0 | 0 | 100 |  | 0 | ELOUADRHIRI L | 1 | 1 | D | LATIFA E | 4211 |  | 12-024 |  |  |  |  |  |  |  |  | 13-002F |  | 24272180 |  | 13-015 | PR | OB |  |  | EJ |  |
| 24271735LOE |  | JLab support of FNAL Torus CCM effort FY14 |  | 184d | 2013-10-01 A | 2014-07-01 | 24271730LOE | 12% | 161d | 2013-11-01 | 2014-08-04 | 72d | 0d | 8/5 M-F w/JLAB Holidays ReBaseline | SR STAFF [1266 h] | 152,325.12 | 19,040.64 |  |  |  |  |  | 19040.64 | ELOUADRHIRI L | 1 | 1 | E | LATIFA E | 4211 |  | 12-024 | 87.5 | 12.5 | 100 | 100 | 13-005 |  |  |  | 13-002F |  | 24271735LOE |  | 13-015 | PR |  |  |  | EJ | 14-001 |
| 24271700 |  | FNAL: Production final CCM#2 and test |  | 96d | 2013-11-01 | 2014-03-31 | 9-140M, 24271695 FS-161d |  |  |  |  | 80d | 10d | 8/5 M-F w/JLAB Holidays ReBaseline | PROCUREMENT<$50K 60 NO ESCALATION; PROCUREMENT>$50K 69 NO ESCALATION | 123,134.83 |  | 123134.83 | 0 | 0 | 100 |  | 0 | ELOUADRHIRI L | 1 | 1 | D | LATIFA E | 4211 |  |  |  |  |  |  |  | 12-042 |  |  | 13-002F |  | 24271700 | VQ | 13-015 | PR |  |  |  |  |  |
| 24271705 |  | FNAL: Production final CCM#3 and test |  | 118d | 2013-11-01 | 2014-04-30 | 24271700 FS-162d |  |  |  |  | 77d | 0d | 8/5 M-F w/JLAB Holidays ReBaseline | PROCUREMENT>$50K 69 NO ESCALATION | 123,134.83 |  | 123134.83 | 0 | 0 | 100 |  | 0 | ELOUADRHIRI L | 1 | 1 | D | LATIFA E | 4211 |  |  |  |  |  |  |  | 12-042 |  |  | 13-002F |  | 24271705 | VQ | 13-015 | PR |  |  |  |  |  |
| 24271710 |  | FNAL: Production final CCM#4 and test |  | 139d | 2013-11-01 | 2014-05-30 | 24271705 FS-183d |  |  |  |  | 73d | 0d | 8/5 M-F w/JLAB Holidays ReBaseline | PROCUREMENT>$50K 69 NO ESCALATION | 123,134.83 |  | 123134.83 | 0 | 0 | 100 |  | 0 | ELOUADRHIRI L | 1 | 1 | D | LATIFA E | 4211 |  |  |  |  |  |  |  | 12-042 |  |  | 13-002F |  | 24271710 | VQ | 13-015 | PR |  |  |  |  |  |
| 24271715 |  | FNAL: Production final CCM#5 and test |  | 160d | 2013-11-01 | 2014-06-30 | 24271710 FS-205d |  |  |  |  | 63d | 0d | 8/5 M-F w/JLAB Holidays ReBaseline | PROCUREMENT>$50K 69 NO ESCALATION | 123,134.83 |  | 123134.83 | 0 | 0 | 100 |  | 0 | ELOUADRHIRI L | 1 | 1 | D | LATIFA E | 4211 |  |  |  |  |  |  |  | 12-042 |  |  | 13-002F |  | 24271715 | VQ | 13-015 | PR |  |  |  |  |  |
| 24271720 |  | FNAL: Production final CCM#6 and test |  | 179d | 2013-11-01 | 2014-07-28 | 24271715 FS-226d |  |  |  |  | 45d | 0d | 8/5 M-F w/JLAB Holidays ReBaseline | PROCUREMENT>$50K 69 NO ESCALATION | 123,134.83 |  | 123134.83 | 0 | 0 | 100 |  | 0 | ELOUADRHIRI L | 1 | 1 | D | LATIFA E | 4211 |  |  |  |  |  |  |  | 12-042 |  |  | 13-002F |  | 24271720 | VQ | 13-015 | PR |  |  | Y |  |  |
| 24271740M |  | FNAL Torus work complete | milestone | 0d | 2014-07-28 | 2014-07-28 | 24271720 |  |  |  |  | 45d | 0d | 8/5 M-F w/JLAB Holidays ReBaseline |  |  |  |  |  |  |  |  | 0 | ELOUADRHIRI L | 1 | 1 | M | LATIFA E | 4211 |  |  |  |  |  |  |  | 12-042 |  |  | 13-002F |  | 24271740M |  | 13-015 | PR |  |  |  |  |  |

Notes:
- 14271012: Steps: Preliminary Design (done); Intermediate Design (done); Final Design (done)
- 14271040: Steps: Risk Assessment and Mitigation Plan Production (done); Begin writing lifting, welding, incoming material QA, mat. handeling, MLI Apllication, OSP and Assembly Procedure (done); Begin review of lifting, welding, incoming material QA, mat. handeling, MLI Apllication, OSP and Assembly Procedure (done); Complete all procedures except for Assy (done); Complete assy Procedure (done); Testing Procured equipment (done)
- 14271045: Steps: Cryostat Factory Phase 2 (done)

| ID | WBS | Activity | Type | Duration | Start | Finish | Predecessors | Complete | Remaining | Planned start | Planned finish | Total float | Free float | Calendar | Resources | Cost | Actual cost | LOE % Pre Calc | LOE % | LOE Divider | LOE Multiplier | Calculated Remaining Total Cost | MONTHLY EV COST | RESP - Responsibility | STRT%COMP for CM EVM | FNSH%COMP for CM EVM | EVMS Reporting Codes | CAM RESPONSIBLE | 12 GEV MAJOR PROCUREMENT CATAGORY | CR 12-011 | CR 12-024 | CR 13-004 | Remaining Material Cost Based on % Compl | Claimed Material Cost Based on % Complet | Initial Claimed Material Calc | Claimed Material Divider | CR 13-008 | CR 12-054 | ReBaseline Actuals Adjustment | Original Activity ID Rebaseline | PRIOR MONTH EV COST | BOE Procurement | CR 13-015 | Post Rebaseline | Obligated Prior to Rebaseline | SC Magnet Dates | CR 14-001 |
| --- | --- | --- | --- | --- | --- | --- | --- | --- | --- | --- | --- | --- | --- | --- | --- | --- | --- | --- | --- | --- | --- | --- | --- | --- | --- | --- | --- | --- | --- | --- | --- | --- | --- | --- | --- | --- | --- | --- | --- | --- | --- | --- | --- | --- | --- | --- | --- |
|  | 2 | **1.4.2.7.2 SOLENOID MAGNET NEW VENDOR** |  |  | 2012-06-01 | 2015-11-02 |  |  |  |  |  |  |  |  |  |  |  |  |  |  |  |  |  |  |  |  |  |  |  |  |  |  |  |  |  |  |  |  |  |  |  |  |  |  |  |  |  |
| 14271055 |  | JLab Design and Support Labor FY12 |  | 84d | 2012-06-01 A | 2012-09-28 A | 9-120M FS+163d | 100% |  |  |  |  |  |  | MECH ENG [1273.33 h] | 89,285.9 | 89,285.9 | 22.61904761 | 77.38095238 | 100 | 100 | 0 | 89285.8996 | ELOUADRHIRI L | 1 | 1 | E | LATIFA E | 4211 | 12-011 | 12-024 |  |  |  |  |  |  |  |  |  |  |  |  |  |  |  |  |
| 14271060 |  | JLab Design and Support Labor FY13 |  | 248d | 2012-10-01 A | 2013-08-30 A | 14271055 | 100% |  | 2012-10-01 | 2013-09-30 |  |  |  | MECH ENG [567.22 h] | 41,044.04 | 41,044.04 | 8.06451612 | 91.93548387 | 100 | 100 | 7562.80757232 | 41044.0392 | ELOUADRHIRI L | 1 | 1 | E | LATIFA E | 4211 | 12-011 | 12-024 |  |  |  |  |  |  |  |  |  |  |  |  |  |  |  |  |
| 14271068M |  | Award Solenoid Contract | milestone | 0d | 2012-11-27 A | 2012-11-27 A | 9-130M FS+39d | 100% |  |  |  |  |  |  |  |  |  |  |  |  |  |  | 0 | ELOUADRHIRI L | 1 | 1 | M | LATIFA E | 4211 |  |  | 13-004 |  |  |  |  |  |  |  |  |  |  |  |  |  |  |  |
| 14271070 |  | Vend Fab Solenoid - Peg Point #1 - Preliminary Design Review |  | 81d | 2012-11-27 A | 2013-03-18 A | 14271068M | 100% |  | 2012-11-27 | 2013-03-29 |  |  |  | PROCUREMENT<$50K 60 NO ESCALATION; PROCUREMENT>$50K 69 NO ESCALATION | 199,085 |  |  |  |  |  | 0 | 199085 | ELOUADRHIRI L | 1 | 1 | P | LATIFA E | 4211 |  | 12-024 | 13-004 | 0 | 199085 | 19908500 | 100 |  |  |  |  |  |  |  |  |  |  |  |
| 14271075 |  | Vend Fab Solenoid - Peg Point #2 - Intermediate Design Review |  | 125d | 2012-11-27 A | 2013-08-30 A | 14271070 FS-81d | 100% |  | 2012-11-27 | 2013-05-31 |  |  |  | PROCUREMENT>$50K 69 NO ESCALATION | 99,543 |  |  |  |  |  | 49771.5 | 99543 | ELOUADRHIRI L | 1 | 1 | D | LATIFA E | 4211 |  | 12-024 | 13-004 | 0 | 99543 | 9954300 | 100 | 13-008 |  |  |  |  |  |  |  |  |  |  |
| 14271075a |  | Vend Fab Solenoid - Peg Point #3 - Final Design Review |  | 145d | 2012-11-27 A | 2013-08-30 A | 14271075 FS-125d | 100% |  | 2012-11-27 | 2013-06-28 |  |  |  | PROCUREMENT>$50K 69 NO ESCALATION | 99,543 |  |  |  |  |  | 99543 | 99543 | ELOUADRHIRI L | 1 | 1 | P | LATIFA E | 4211 |  |  | 13-004 | 0 | 99543 | 9954300 | 100 |  |  |  |  |  |  |  |  |  |  |  |
| 14271075c |  | Vend Fab Solenoid - Peg Point #4 - Winding and Potting Tooling |  | 189d | 2012-11-27 A | 2013-08-30 A | 14271075b FS-145d | 100% |  |  |  |  |  |  | PROCUREMENT>$50K 69 NO ESCALATION | 79,634 |  |  |  |  |  | 79634 | 79634 | ELOUADRHIRI L | 1 | 1 | P | LATIFA E | 4211 |  |  | 13-004 | 0 | 79634 | 7963400 | 100 |  |  |  |  |  |  |  |  |  |  |  |
| 14271075b |  | Vend Fab Solenoid - Final Design Review Incetive Fee |  | 112d | 2013-01-14 A | 2013-08-30 A | 14271075a FS-128d | 100% |  | 2013-01-14 | 2013-06-21 |  |  |  | PROCUREMENT>$50K 69 NO ESCALATION | 200,000 |  |  |  |  |  | 200000 | 200000 | ELOUADRHIRI L | 1 | 1 | P | LATIFA E | 4211 |  |  | 13-004 | 0 | 200000 | 20000000 | 100 |  |  |  |  |  |  |  |  |  |  |  |
| 14271080 |  | Machine Shop Effort |  | 148d | 2013-08-30 A | 2013-08-30 A | 9-130M FS+100d | 100% |  | 2013-09-03 | 2014-04-10 |  |  |  | MSHOP | 183,567.85 |  |  |  |  |  | 212250.33 | 183567.85 | ELOUADRHIRI L | 1 | 1 | P | LATIFA E | 4211 | 12-011 | 12-024 |  |  |  |  |  |  | 12-054 |  |  |  |  |  |  |  |  |  |
| 14271090 |  | Re-Baseline Actuals Adjustment |  | 1d | 2013-08-30 A | 2013-08-30 A |  | 100% |  | 2013-09-03 | 2013-09-03 |  |  |  | PROCUREMENT>$50K 69 NO ESCALATION | -328,437.4 |  |  |  |  |  |  |  |  |  |  |  |  |  |  |  |  |  |  |  | 100 |  |  | ADJ |  |  |  |  |  |  |  |  |
| 24272075 |  | Vend Fab Solenoid - Peg Point #2 - Intermediate Design Review |  | 43d | 2013-09-03 A | 2013-09-23 A | 9-130M FS+228d | 100% |  | 2013-10-01 | 2013-12-02 |  |  | 8/5 M-F w/JLAB Holidays ReBaseline | PROCUREMENT>$50K 69 NO ESCALATION | 49,771.5 |  |  |  |  |  |  | 0 | ELOUADRHIRI L | 1 | 1 | D | LATIFA E | 4211 |  | 12-024 | 13-004 | 0 | 49771.5 | 4977150 | 100 | 13-008 |  |  | 24272075 | 49771.5 | OB | 13-015 | PR | OB |  |  |
| 24272075a |  | Vend Fab Solenoid - Peg Point #3 - Final Design Review |  | 77d | 2013-09-03 A | 2014-03-25 | 24272075 FS-43d | 75% | 92d | 2013-10-01 | 2014-01-30 | 21d | 0d | 8/5 M-F w/JLAB Holidays ReBaseline | PROCUREMENT>$50K 69 NO ESCALATION | 99,543 |  |  |  |  |  |  | 0 | ELOUADRHIRI L | 1 | 1 | D | LATIFA E | 4211 |  |  | 13-004 | 24885.75 | 74657.25 | 7465725 | 100 |  |  |  | 24272075a | 74657.25 | OB | 13-015 | PR | OB | Y |  |
| 24272075b |  | Vend Fab Solenoid - Final Design Review Incetive Fee |  | 77d | 2013-09-03 A | 2014-02-04 | 24272075a FS-95d |  | 57d | 2013-10-01 | 2014-01-30 | 38d | 20d | 8/5 M-F w/JLAB Holidays ReBaseline | PROCUREMENT>$50K 69 NO ESCALATION | 200,000 |  |  |  |  |  |  | 0 | ELOUADRHIRI L | 1 | 1 | D | LATIFA E | 4211 |  |  | 13-004 | 200000 | 0 | 0 | 100 |  |  |  | 24272075b |  | OB | 13-015 | PR | OB |  |  |
| 24272075c |  | Vend Fab Solenoid - Peg Point #4 - Winding and Potting Tooling |  | 118d | 2013-09-03 A | 2014-04-02 | 24272075ba FS-95d, 24272075b FS-77d |  | 98d | 2013-10-01 | 2014-03-28 | 18d | 20d | 8/5 M-F w/JLAB Holidays ReBaseline | PROCUREMENT>$50K 69 NO ESCALATION | 79,634 |  |  |  |  |  |  | 0 | ELOUADRHIRI L | 1 | 1 | D | LATIFA E | 4211 |  |  | 13-004 | 79634 | 0 | 0 | 100 |  |  |  | 24272075c |  | OB | 13-015 | PR | OB |  |  |
| 24272075d |  | Vend Fab Solenoid - Peg Point #5 - PSMM Fabrication and Testing |  | 203d | 2013-09-03 A | 2014-07-02 | 24272075c FS-118d |  | 162d | 2013-10-01 | 2014-07-29 | -2d | 41d | 8/5 M-F w/JLAB Holidays ReBaseline | PROCUREMENT>$50K 69 NO ESCALATION | 119,452 |  |  |  |  |  |  | 0 | ELOUADRHIRI L | 1 | 1 | D | LATIFA E | 4211 |  |  | 13-004 | 119452 | 0 | 0 | 100 |  |  |  | 24272075d |  | OB | 13-015 | PR | OB |  |  |
| 24272075f |  | Vend Fab Solenoid - MRR Incentive Fee |  | 225d | 2013-09-03 A | 2014-07-31 | 24272075d FS-203d |  | 182d | 2013-10-01 | 2014-08-28 | -43d | 43d | 8/5 M-F w/JLAB Holidays ReBaseline | PROCUREMENT>$50K 69 NO ESCALATION | 200,000 |  |  |  |  |  |  | 0 | ELOUADRHIRI L | 1 | 1 | D | LATIFA E | 4211 |  |  | 13-004 | 200000 | 0 | 0 | 100 |  |  |  | 24272075f |  | OB | 13-015 | PR | OB |  |  |
| 24272075g |  | Vend Fab Solenoid - Peg Point #6 - Coils Wound |  | 246d | 2013-09-03 A | 2014-12-23 | 24272075f FS-225d, 24273010Q FS-250d, 24273010R FS-139d, 24273010P FS-125d, 24273010K FS-139d |  | 282d | 2013-10-01 | 2014-09-29 | -86d | 18d | 8/5 M-F w/JLAB Holidays ReBaseline | PROCUREMENT>$50K 69 NO ESCALATION | 199,085 |  |  |  |  |  |  | 0 | ELOUADRHIRI L | 1 | 1 | D | LATIFA E | 4211 |  |  | 13-004 | 199085 | 0 | 0 | 100 |  |  |  | 24272075g |  | OB | 13-015 | PR | OB | Y |  |
| 24272075h |  | Vend Fab Solenoid - Peg Point #7 - Cryostat Materials and Components |  | 267d | 2013-09-03 A | 2014-09-30 | 24272075g FS-300d |  | 224d | 2013-10-01 | 2014-10-28 | -104d | 43d | 8/5 M-F w/JLAB Holidays ReBaseline | PROCUREMENT>$50K 69 NO ESCALATION | 298,628 |  |  |  |  |  |  | 0 | ELOUADRHIRI L | 1 | 1 | D | LATIFA E | 4211 |  |  | 13-004 | 298628 | 0 | 0 | 100 |  |  |  | 24272075h |  | OB | 13-015 | PR | OB |  |  |
| 24272075j |  | Vend Fab Solenoid - Peg Point #8 - Cold Mass Materials and Components |  | 290d | 2013-09-03 A | 2014-12-05 | 24272075h FS-267d |  | 270d | 2013-10-01 | 2014-12-02 | -147d | 20d | 8/5 M-F w/JLAB Holidays ReBaseline | PROCUREMENT>$50K 69 NO ESCALATION | 298,628 |  |  |  |  |  |  | 0 | ELOUADRHIRI L | 1 | 1 | D | LATIFA E | 4211 |  |  | 13-004 | 298628 | 0 | 0 | 100 |  |  |  | 24272075j |  | OB | 13-015 | PR | OB |  |  |
| 24272075k |  | Vend Fab Solenoid - Peg Point #9 - Assembly and Test |  | 308d | 2013-09-03 A | 2015-08-31 | 24272075j FS-290d |  | 449d | 2013-10-01 | 2015-01-07 | -167d | 0d | 8/5 M-F w/JLAB Holidays ReBaseline | PROCUREMENT>$50K 69 NO ESCALATION | 199,085 |  |  |  |  |  |  | 0 | ELOUADRHIRI L | 1 | 1 | D | LATIFA E | 4211 |  |  | 13-004 | 199085 | 0 | 0 | 100 |  |  |  | 24272075k |  | OB | 13-015 | PR | OB | Y |  |
| 24272075n |  | Vend Fab Solenoid - Delivery Incentive Fee |  | 308d | 2013-09-03 A | 2015-01-12 | 24272075k FS-500d |  | 288d | 2013-10-01 | 2015-01-07 | -6d | 161d | 8/5 M-F w/JLAB Holidays ReBaseline | PROCUREMENT>$50K 69 NO ESCALATION | 600,000 |  |  |  |  |  |  | 0 | ELOUADRHIRI L | 1 | 1 | D | LATIFA E | 4211 |  |  | 13-004 | 600000 | 0 | 0 | 100 |  |  |  | 24272075n |  | OB | 13-015 | PR | OB |  |  |
| 24272075p |  | Vend Fab Solenoid - Peg Point #10 - Commissioning and Acceptance Test |  | 449d | 2013-09-03 A | 2015-09-30 | 24272075n FS-500d |  | 470d | 2013-10-01 | 2015-07-29 | 55d | 0d | 8/5 M-F w/JLAB Holidays ReBaseline | PROCUREMENT>$50K 69 NO ESCALATION | 199,085 |  |  |  |  |  |  | 0 | ELOUADRHIRI L | 1 | 1 | D | LATIFA E | 4211 |  |  | 13-004 | 199085 | 0 | 0 | 100 |  |  |  | 24272075p |  | OB | 13-015 | PR | OB |  |  |
| 24272075q |  | Vend Fab Solenoid - Peg Point #11 - Final Report and Closeout |  | 513d | 2013-09-03 A | 2015-11-02 | 24272075p FS-470d |  | 493d | 2013-10-01 | 2015-10-28 | 55d | 20d | 8/5 M-F w/JLAB Holidays ReBaseline | PROCUREMENT>$50K 69 NO ESCALATION | 199,085 |  |  |  |  |  |  | 0 | ELOUADRHIRI L | 1 | 1 | D | LATIFA E | 4211 |  |  | 13-004 | 199085 | 0 | 0 | 100 |  |  |  | 24272075q |  | OB | 13-015 | PR | OB |  |  |
| 24272075r |  | Vend Fab Solenoid - Peg Point #12 - Shipping Costs |  | 513d | 2013-09-03 A | 2015-11-02 | 24272075q FS-513d |  | 493d | 2013-10-01 | 2015-10-28 | 35d | 128d | 8/5 M-F w/JLAB Holidays ReBaseline | PROCUREMENT>$50K 69 NO ESCALATION | 6,000 |  |  |  |  |  |  | 0 | ELOUADRHIRI L | 1 | 1 | D | LATIFA E | 4211 |  |  | 13-004 | 6000 | 0 | 0 | 100 |  |  |  | 24272075r |  | OB | 13-015 | PR | OB |  |  |
| 24272080 |  | Solenoid Outside Consulting FY13 |  | 98d | 2013-09-03 A | 2014-01-31 | 9-130M FS+228d | 80% | 55d | 2013-10-01 | 2014-02-28 | 606d | 0d | 8/5 M-F w/JLAB Holidays ReBaseline | PROCUREMENT<$50K 60 NO ESCALATION FY14; PROCUREMENT>$50K 69 NO ESCALATION FY14 | 178,380 |  |  |  |  |  |  | 107028 | ELOUADRHIRI L | 1 | 1 | D | LATIFA E | 4211 |  |  | 13-004 | 35676 | 142704 | 14270400 | 100 |  |  |  | 24272080 | 35676 | OB | 13-015 | PR | OB |  |  |
| 24272405 |  | Solenoid - Cable Testing |  | 118d | 2013-09-03 A | 2014-04-02 | 9-130M FS+228d |  | 98d | 2013-10-01 | 2014-03-28 | 430d | 523d | 8/5 M-F w/JLAB Holidays ReBaseline | PROCUREMENT<$50K 60 NO ESCALATION FY14 | 24,000 |  |  |  |  |  |  | 0 | ELOUADRHIRI L | 1 | 1 | D | LATIFA E | 4211 |  |  | 13-004 | 24000 | 0 | 0 | 100 |  |  |  | 24272405 |  | OB | 13-015 | PR | OB |  |  |
| 24272410 |  | Consultant Fees WS |  | 267d | 2013-09-03 A | 2014-10-31 | 9-130M FS+228d | 70% | 247d | 2013-10-01 | 2014-10-28 | 281d | 374d | 8/5 M-F w/JLAB Holidays ReBaseline | PROCUREMENT<$50K 60 NO ESCALATION FY14 | 8,050 |  |  |  |  |  |  | 0 | ELOUADRHIRI L | 1 | 1 | D | LATIFA E | 4211 |  |  | 13-004 | 2415 | 5635 | 563500 | 100 |  |  |  | 24272405 | 5635 | OB | 13-015 | PR | OB |  |  |
| 24272085 |  | Solenoid Outside Consulting FY14 |  | 305d | 2014-02-03 | 2015-04-23 | 24272080 |  |  |  |  | 606d | 761d | 8/5 M-F w/JLAB Holidays ReBaseline | PROCUREMENT<$50K 60 NO ESCALATION FY15; PROCUREMENT>$50K 69 NO ESCALATION FY15 | 185,742 |  |  |  |  |  |  | 0 | ELOUADRHIRI L | 1 | 1 | D | LATIFA E | 4211 |  |  | 13-004 | 185742 | 0 | 0 | 100 |  |  |  | 24272085 |  | EJ | 13-015 | PR |  |  | 14-001 |
| 24272075ba |  | De-Obligation of Vend Fab Solenoid - Final Design Review Incetive Fee |  | 1d | 2014-03-25 | 2014-03-25 | 24272075a FS-1d |  |  |  |  | 21d | 3d | 8/5 M-F w/JLAB Holidays ReBaseline | PROCUREMENT>$50K 69 NO ESCALATION | -135,000 |  |  |  |  |  |  | 0 | ELOUADRHIRI L | 1 | 1 | D | LATIFA E | 4211 |  |  | 13-004 | -135000 | 0 | 0 | 100 |  |  |  | 24272075b |  | OB | 13-015 | PR |  |  |  |

| ID | WBS | Activity | Duration | Start | Finish | Predecessors | Complete | Remaining | Planned start | Planned finish | Total float | Free float | Calendar | Resources | Cost | Actual cost | Remaining Material Cost Based on % Compl | Claimed Material Cost Based on % Complet | Initial Claimed Material Calc | Claimed Material Divider | Calculated Remaining Total Cost | MONTHLY EV COST | RESP - Responsibility | STRT%COMP for CM EVM | FNSH%COMP for CM EVM | EVMS Reporting Codes | CAM RESPONSIBLE | CR 12-011 | CR 12-024 | Activities with Steps | CR 12-046 | MARCH!!! | CR 12-054 | CR 13-005 | ReBaseline Actuals Adjustment | Original Activity ID Rebaseline | CR 13-002 | BOE Procurement | CR 13-015 | Post Rebaseline | Obligated Prior to Rebaseline | PRIOR MONTH EV COST | BOE Labor | BOE Expenses | CR 14-001 |
| --- | --- | --- | --- | --- | --- | --- | --- | --- | --- | --- | --- | --- | --- | --- | --- | --- | --- | --- | --- | --- | --- | --- | --- | --- | --- | --- | --- | --- | --- | --- | --- | --- | --- | --- | --- | --- | --- | --- | --- | --- | --- | --- | --- | --- | --- |
|  | 3 | **1.4.2.7.3 MAGNET INFRASTRUCTURE** |  | 2011-12-05 | 2014-05-01 |  |  |  |  |  |  |  |  |  |  |  |  |  |  |  |  |  |  |  |  |  |  |  |  |  |  |  |  |  |  |  |  |  |  |  |  |  |  |  |  |
| 14273005 |  | Set up Solder Production line Procurements | 120d | 2011-12-05 A | 2012-05-31 A | 9-120M FS+41d | 100% |  |  |  |  |  |  | PROCUREMENT<$50K 60; PROCUREMENT>$50K 69 | 150,000 |  | 0 | 150000 | 15000000 | 100 | 0 | 150000 | ELOUADRHIRI L | 1 | 1 | D | LATIFA E | 12-011 | 12-024F |  |  |  |  |  |  |  |  |  |  |  |  |  |  |  |  |
| 14273000 |  | Set up Solder Production line Labor Original | 52d | 2012-01-03 A | 2012-03-19 A | 9-120M FS+41d | 100% |  | 2012-01-03 | 2012-03-16 |  |  |  | MECH ENG [308.58 h]; MECH TECH [973.78 h] | 64,912.41 | 64,912.41 |  |  |  |  | 0 | 64912.4128 | ELOUADRHIRI L | 1 | 1 | S | LATIFA E | 12-011 | 12-024 | ST |  |  |  |  |  |  |  |  |  |  |  |  |  |  |  |
| 14273003 |  | Set up Solder Production line Labor Revised | 22d | 2012-05-01 A | 2012-05-31 A | 14273000 | 100% |  |  |  |  |  |  | MECH ENG [166.8 h]; MECH TECH [526.37 h] | 35,087.9 | 35,087.9 |  |  |  |  | 0 | 35087.8988 | ELOUADRHIRI L | 1 | 1 | H | LATIFA E | 12-011 | 12-024 |  |  |  |  |  |  |  |  |  |  |  |  |  |  |  |  |
| 14273014 |  | Design/Build/Install guides and rollers for inlet/outlet of process | 30d | 2012-08-06 A | 2012-09-17 A | 9-120M FS+205d | 100% |  |  |  |  |  |  | ELEC TECH [40 h]; ELEC ENG [20 h]; SUPPLIES & MATERIALS | 3,676.4 | 3,176.4 |  |  |  |  | 0 | 3676.4 | ELOUADRHIRI L | 1 | 1 | H | LATIFA E |  | 12-024 |  | 12-046 |  |  |  |  |  |  |  |  |  |  |  |  |  |  |
| 14273011 |  | Wave Solder of Torus and Solenoid Magnets Travel FY12 | 95d | 2012-08-14 A | 2013-02-18 A | 9-120M FS+217d | 100% |  | 2012-08-14 | 2013-01-04 |  |  |  | TRAVEL; SCIENTIST [84 h]; MECH TECH [168 h] | 23,476.2 | 13,710.93 |  |  |  |  | 0 | 23197.16 | ELOUADRHIRI L | 1 | 1 | S | LATIFA E |  | 12-024 | ST | 12-046 | XX |  |  |  |  |  |  |  |  |  |  |  |  |  |
| 14273010 |  | Vend Fab Wave Solder of Torus and Solenoid Magnets Peg Point #1A-Soldering Setup Part A | 41d | 2012-08-17 A | 2012-10-15 A | 9-120M FS+163d, 14273003 | 100% |  |  |  |  |  |  | PROCUREMENT<$50K 60 NO ESCALATION; PROCUREMENT>$50K 69 NO ESCALATION | 61,384 |  | 0 | 61384 | 6138400 | 100 | 0 | 61384 | ELOUADRHIRI L | 1 | 1 | D | LATIFA E |  | 12-024 |  | 12-046 |  |  |  |  |  |  |  |  |  |  |  |  |  |  |
| 14273010A |  | Vend Fab Wave Solder of Torus and Solenoid Magnets Peg Point #1-Soldering Setup Part B | 92d | 2012-08-17 A | 2013-02-11 A | 14273008 FS-125d, 14273007 FS-65d, 14273010 FS-20d | 100% |  | 2012-08-17 | 2013-01-04 |  |  |  | PROCUREMENT>$50K 69 NO ESCALATION | 38,616 |  | 0 | 38616 | 3861600 | 100 | 0 | 38616 | ELOUADRHIRI L | 1 | 1 | D | LATIFA E |  | 12-024 |  | 12-046 | XX |  |  |  |  |  |  |  |  |  |  |  |  |  |
| 14273010B |  | Vend Fab Wave Solder of Torus and Solenoid Magnets Peg Point #2-Procurement of Materials and Start of Production | 115d | 2012-08-17 A | 2013-03-18 A | 14273010A FS-30d | 100% |  | 2012-08-17 | 2013-02-07 |  |  |  | PROCUREMENT>$50K 69 NO ESCALATION | 125,000 |  | 0 | 125000 | 12500000 | 100 | 0 | 125000 | ELOUADRHIRI L | 1 | 1 | D | LATIFA E |  | 12-024 |  | 12-046 |  |  |  |  |  |  |  |  |  |  |  |  |  |  |
| 14273010C |  | Vend Fab Wave Solder of Torus and Solenoid Magnets Peg Point #3-Delivery of Torus Conductor 001 | 93d | 2012-08-17 A | 2013-03-18 A | 14273010B FS-53d | 100% |  | 2012-08-17 | 2013-01-07 |  |  |  | PROCUREMENT>$50K 69 NO ESCALATION | 21,060 |  | 0 | 21060 | 2106000 | 100 | 0 | 21060 | ELOUADRHIRI L | 1 | 1 | D | LATIFA E |  | 12-024 |  | 12-046 | XX |  |  |  |  |  |  |  |  |  |  |  |  |  |
| 14273010D |  | Vend Fab Wave Solder of Torus and Solenoid Magnets Peg Point #4-Delivery of Torus Conductor 002-006 | 130d | 2012-08-17 A | 2013-06-17 A | 14273010C FS-73d | 100% |  | 2012-08-17 | 2013-03-01 |  |  |  | PROCUREMENT>$50K 69 NO ESCALATION | 125,000 |  | 0 | 125000 | 12500000 | 100 | 0 | 125000 | ELOUADRHIRI L | 1 | 1 | D | LATIFA E |  | 12-024 |  | 12-046 |  |  |  |  |  |  |  |  |  |  |  |  |  |  |
| 14273010G |  | Vend Fab Wave Solder of Torus and Solenoid Magnets Peg Point #5-Delivery of 1st set of Solenoid Conductor Lengths 1-9 | 170d | 2012-08-17 A | 2013-08-30 A | 14273010D FS-110d | 100% |  | 2012-08-17 | 2013-04-26 |  |  |  | PROCUREMENT>$50K 69 NO ESCALATION | 92,985 |  | 0 | 92985 | 9298500 | 100 | 92985 | 92985 | ELOUADRHIRI L | 1 | 1 | D | LATIFA E |  | 12-024 |  | 12-046 |  |  |  |  |  |  |  |  |  |  |  |  |  |  |
| 14273010H |  | Vend Fab Wave Solder of Torus and Solenoid Magnets Peg Point #6-Delivery of 2nd set of Solenoid Conductor Lengths 1-9 | 170d | 2012-08-17 A | 2013-08-30 A | 14273010G FS-150d | 100% |  | 2012-08-17 | 2013-04-26 |  |  |  | PROCUREMENT>$50K 69 NO ESCALATION | 92,985 |  | 0 | 92985 | 9298500 | 100 | 92985 | 92985 | ELOUADRHIRI L | 1 | 1 | D | LATIFA E |  | 12-024 |  | 12-046 |  |  |  |  |  |  |  |  |  |  |  |  |  |  |
| 14273010J |  | Vend Fab Wave Solder of Torus and Solenoid Magnets Peg Point #7-Delivery of 3rd set of Solenoid Conductor Lengths 1-9 | 192d | 2012-08-17 A | 2013-08-30 A | 14273010H FS-150d | 100% |  | 2012-08-17 | 2013-05-29 |  |  |  | PROCUREMENT>$50K 69 NO ESCALATION | 92,985 |  | 0 | 92985 | 9298500 | 100 | 92985 | 92985 | ELOUADRHIRI L | 1 | 1 | D | LATIFA E |  | 12-024 |  | 12-046 |  |  |  |  |  |  |  |  |  |  |  |  |  |  |
| 14273010K |  | Vend Fab Wave Solder of Torus and Solenoid Magnets Peg Point #8-Delivery of 4th set of Solenoid Conductor Lengths 1-9 | 234d | 2012-08-17 A | 2013-08-30 A | 14273010J FS-172d | 100% |  | 2012-08-17 | 2013-07-29 |  |  |  | PROCUREMENT>$50K 69 NO ESCALATION | 92,985 |  | 0 | 92985 | 9298500 | 100 | 92985 | 92985 | ELOUADRHIRI L | 1 | 1 | D | LATIFA E |  | 12-024 |  | 12-046 |  |  |  |  |  |  |  |  |  |  |  |  |  |  |
| 14273008 |  | Additional Cu Channel and Wagon wheel spools for Torus | 31d | 2012-09-10 A | 2012-10-22 A | 9-130M | 100% |  |  |  |  |  |  | PROCUREMENT<$50K 60 | 54,690.7 |  | 0 | 54690.7 | 5469070 | 100 | 0 | 54690.7 | ELOUADRHIRI L | 1 | 1 | D | LATIFA E |  | 12-024 |  | 12-046 |  |  |  |  |  |  |  |  |  |  |  |  |  |  |
| 14273014B |  | Unspool/Measure/Respool/Inspect | 88d | 2012-09-10 A | 2012-12-17 A | 14273014A FS-40d | 100% |  | 2012-09-10 | 2013-01-22 |  |  |  | MECH TECH [420 h] | 19,159.54 | 19,131.55 |  |  |  |  | 0 | 19261.2 | ELOUADRHIRI L | 1 | 1 | H | LATIFA E |  | 12-024 |  | 12-046 |  |  |  |  |  |  |  |  |  |  |  |  |  |  |
| 14273007 |  | Shipping of Coductor to AES | 63d | 2012-10-01 A | 2013-08-30 A | 9-130M | 100% |  | 2012-10-01 | 2013-01-07 |  |  |  | PROCUREMENT<$50K 60 | 10,319 |  | 0 | 10319 | 1031900 | 100 | 8874.34 | 10319 | ELOUADRHIRI L | 1 | 1 | D | LATIFA E |  | 12-024 |  | 12-046 | XX | 12-054 |  |  |  |  |  |  |  |  |  |  |  |  |
| 14273014A |  | Dial in the process settings - spooling and traverse speeds, manual control | 20d | 2012-12-03 A | 2012-12-17 A | 14273014 | 100% |  | 2013-01-02 | 2013-01-30 |  |  |  | ELEC TECH [20 h]; ELEC ENG [10 h]; SR STAFF [16 h] | 3,504.5 | 3,504.5 |  |  |  |  | 0 | 3504.5 | ELOUADRHIRI L | 1 | 1 | H | LATIFA E |  | 12-024 |  | 12-046 |  |  |  |  |  |  |  |  |  |  |  |  |  |  |
| 14273015 |  | Cryostat Factory Setup | 16d | 2012-12-03 A | 2012-12-17 A | 9-130M | 100% |  | 2013-01-02 | 2013-01-24 |  |  |  | MECH ENG [587.13 h]; MECH TECH [463.2 h]; MECH DES [427.33 h] | 84,969.65 | 84,969.65 |  |  |  |  | 0 | 84969.6531 | ELOUADRHIRI L | 1 | 1 | P | LATIFA E | 12-011 | 12-024 |  |  |  |  | 13-005 |  |  |  |  |  |  |  |  |  |  |  |
| 14273012 |  | Wave Solder of Torus and Solenoid Magnets Travel FY13 | 184d | 2013-02-11 A | 2013-08-30 A | 14273011 | 100% |  | 2013-03-28 | 2013-12-17 |  |  |  | TRAVEL; MECH TECH [576 h]; SCIENTIST [288 h] | 82,513.77 | 47,399.04 |  |  |  |  | 47601.1104 | 82070.88 | ELOUADRHIRI L | 1 | 1 | S | LATIFA E |  | 12-024 | ST | 12-046 |  |  |  |  |  |  |  |  |  |  |  |  |  |  |
| 14273020 |  | Re-Baseline Actuals Adjustment | 1d | 2013-08-30 A | 2013-08-30 A |  | 100% |  | 2013-09-03 | 2013-09-03 |  |  |  | PROCUREMENT>$50K 69 NO ESCALATION | 33,232.83 |  | 0 | 33232.83 | 3323283 | 100 |  | 33232.83 |  |  |  |  |  |  |  |  |  |  |  |  | ADJ |  |  |  |  |  |  |  |  |  |  |
| 24273010B |  | Vend Fab Wave Solder of Torus and Solenoid Magnets Peg Point #2-Procurement of Materials and | 43d | 2013-09-03 A | 2013-12-05 | 9-130M FS+228d |  | 23d | 2013-10-01 | 2013-12-02 | -6d | 20d | 8/5 M-F w/JLAB Holidays ReBaseline | PROCUREMENT>$50K 69 NO ESCALATION | 62,126.25 |  | 62126.25 | 0 | 0 | 100 |  | 0 | ELOUADRHIRI L | 1 | 1 | D | LATIFA E |  | 12-024 |  | 12-046 |  |  |  |  | 24273010B | 13-002F | OB | 13-015 | PR | OB |  |  |  |  |
| 24273010H |  | Vend Fab Wave Solder of Torus and Solenoid Magnets Peg Point #6-Delivery of 2nd set of Solenoid Conductor Lengths 1-9 | 98d | 2013-09-03 A | 2014-03-05 | 24273010B FS-43d |  | 78d | 2013-10-01 | 2014-02-28 | -26d | 20d | 8/5 M-F w/JLAB Holidays ReBaseline | PROCUREMENT>$50K 69 NO ESCALATION | 60,933.75 |  | 60933.75 | 0 | 0 | 100 |  | 0 | ELOUADRHIRI L | 1 | 1 | D | LATIFA E |  | 12-024 |  | 12-046 |  |  |  |  | 24273010H | 13-002F | OB | 13-015 | PR | OB |  |  |  |  |
| 24273010J |  | Vend Fab Wave Solder of Torus and Solenoid Magnets Peg Point #7-Delivery of 3rd set of Solenoid Conductor Lengths 1-9 | 118d | 2013-09-03 A | 2014-04-02 | 24273010H FS-98d |  | 98d | 2013-10-01 | 2014-03-28 | -46d | 20d | 8/5 M-F w/JLAB Holidays ReBaseline | PROCUREMENT>$50K 69 NO ESCALATION | 60,933.75 |  | 60933.75 | 0 | 0 | 100 |  | 0 | ELOUADRHIRI L | 1 | 1 | D | LATIFA E |  | 12-024 |  | 12-046 |  |  |  |  | 24273010J | 13-002F | OB | 13-015 | PR | OB |  |  |  |  |
| 24273010K |  | Vend Fab Wave Solder of Torus and Solenoid Magnets Peg Point #8-Delivery of 4th set of Solenoid Conductor Lengths 1-9 | 139d | 2013-09-03 A | 2014-05-01 | 24273010J FS-118d |  | 119d | 2013-10-01 | 2014-04-28 | -66d | 20d | 8/5 M-F w/JLAB Holidays ReBaseline | PROCUREMENT>$50K 69 NO ESCALATION | 60,933.75 |  | 60933.75 | 0 | 0 | 100 |  | 0 | ELOUADRHIRI L | 1 | 1 | D | LATIFA E |  | 12-024 |  | 12-046 |  |  |  |  | 24273010K | 13-002F | OB | 13-015 | PR | OB |  |  |  |  |
| 24273010N |  | Vend Fab Wave Solder of Torus and Solenoid Magnets Peg Point #9-Additional length and splicing required for Solenoid | 129d | 2013-09-03 A | 2014-04-17 | 24273010K FS-139d |  | 109d | 2013-10-01 | 2014-04-14 | -26d | 20d | 8/5 M-F w/JLAB Holidays ReBaseline | PROCUREMENT<$50K 60 NO ESCALATION FY14; PROCUREMENT>$50K 69 NO ESCALATION | 107,400 |  | 107400 | 0 | 0 | 100 |  | 0 | ELOUADRHIRI L | 1 | 1 | D | LATIFA E |  | 12-024 |  | 12-046 |  |  |  |  | 24273010N | 13-002F | VQ | 13-015 | PR | OB |  |  |  |  |
| 24273010P |  | Vend Fab Wave Solder of Torus and Solenoid Magnets Peg Point #10-Additional Reels for Solenoid | 62d | 2013-09-03 A | 2014-01-13 | 24273010N FS-129d |  | 42d | 2013-10-01 | 2014-01-08 | -46d | 20d | 8/5 M-F w/JLAB Holidays ReBaseline | PROCUREMENT>$50K 69 NO ESCALATION | 79,600 |  | 79600 | 0 | 0 | 100 |  | 0 | ELOUADRHIRI L | 1 | 1 | D | LATIFA E |  | 12-024 |  | 12-046 |  |  |  |  | 24273010P | 13-002F | VQ | 13-015 | PR | OB |  |  |  |  |
| 24273010Q |  | Vend Fab Wave Solder of Torus and Solenoid Magnets Peg Point #10-Conductor Cleaning | 23d | 2013-09-03 A | 2013-09-23 A | 24273010N FS-300d | 100% |  | 2014-03-13 | 2014-04-14 |  |  | 8/5 M-F w/JLAB Holidays ReBaseline | PROCUREMENT>$50K 69 NO ESCALATION | 51,000 |  | 0 | 51000 | 5100000 | 100 |  | 0 | ELOUADRHIRI L | 1 | 1 | D | LATIFA E |  | 12-024 |  | 12-046 |  |  |  |  | 24273010Q | 13-002F | VQ | 13-015 | PR | OB | 51000 |  |  |  |
| 24273010R |  | Vend Fab Wave Solder of Torus and Solenoid Magnets New Scope | 139d | 2013-09-03 A | 2014-05-01 | 24273010P FS-62d | 45% | 119d | 2013-10-01 | 2014-04-28 | -66d | 20d | 8/5 M-F w/JLAB Holidays ReBaseline | PROCUREMENT>$50K 69 NO ESCALATION | 211,308.5 |  | 116219.675 | 95088.825 | 9508882.5 | 100 |  | 0 | ELOUADRHIRI L | 1 | 1 | D | LATIFA E |  | 12-024 |  | 12-046 |  |  |  |  | 24273010Q | 13-002F | VQ | 13-015 | PR | OB | 95088.825 |  |  |  |
| 24273012 |  | Wave Solder of Torus and Solenoid Magnets Travel FY13 | 20d | 2013-09-03 A | 2013-12-02 | 9-130M FS+228d | 40% | 20d | 2013-10-01 | 2013-10-28 | 409d | 0d | 8/5 M-F w/JLAB Holidays ReBaseline | MECH TECH [39.89 h]; SCIENTIST [19.94 h]; TRAVEL | 5,787.59 | 2,278.43 |  |  |  |  |  | 0 | ELOUADRHIRI L | 1 | 1 | S | LATIFA E |  | 12-024 | ST | 12-046 |  |  |  |  | 24273012 | 13-002F |  | 13-015 | PR |  | 2273.2335164 | PE | PE |  |
| 24273017 |  | Twente Cable Testing | 77d | 2013-09-03 A | 2014-02-04 | 9-130M FS+228d |  | 57d | 2013-10-01 | 2014-01-30 | 471d | 564d | 8/5 M-F w/JLAB Holidays ReBaseline | PROCUREMENT<$50K 60 NO ESCALATION FY14 | 12,271.72 |  | 12271.72 | 0 | 0 | 100 |  | 0 | ELOUADRHIRI L | 1 | 1 | D | LATIFA E |  | 12-024 |  | 12-046 |  | 12-054 |  |  | 24273007 | 13-002F | EJ | 13-015 | PR | OB |  |  |  |  |
| 24273022 |  | Additional Cu for solenoid conductor - Procurment | 128d | 2013-09-03 A | 2014-04-16 | 9-130M FS+228d |  | 108d | 2013-10-01 | 2014-04-11 | 420d | 513d | 8/5 M-F w/JLAB Holidays ReBaseline | PROCUREMENT<$50K 60 NO ESCALATION FY14 | 15,500 |  | 15500 | 0 | 0 | 100 |  | 0 | ELOUADRHIRI L | 1 | 1 | D | LATIFA E |  | 12-024 |  | 12-046 |  |  |  |  | 24273022 | 13-002F | EJ | 13-015 | PR | OB |  |  |  |  |
| 24273027 |  | Consultant Fees WS | 77d | 2013-09-03 A | 2013-10-21 A | 9-130M FS+228d | 100% |  | 2013-10-01 | 2014-01-30 |  |  | 8/5 M-F w/JLAB Holidays ReBaseline | PROCUREMENT<$50K 60 NO ESCALATION FY14 | 225 |  | 0 | 225 | 22500 | 100 |  | 225 | ELOUADRHIRI L | 1 | 1 | D | LATIFA E |  | 12-024 |  | 12-046 |  | 12-054 |  |  | 24273007 | 13-002F | EJ | 13-015 | PR | OB |  |  |  |  |
| 24273007 |  | Shipping of Coductor to AES | 43d | 2013-10-01 A | 2013-10-21 A | 9-130M FS+228d | 100% |  | 2013-11-01 | 2014-01-14 |  |  | 8/5 M-F w/JLAB Holidays ReBaseline | PROCUREMENT<$50K 60 NO ESCALATION FY14 | 8,874.34 |  | 0 | 8874.34 | 887434 | 100 |  | 8874.34 | ELOUADRHIRI L | 1 | 1 | D | LATIFA E |  | 12-024 |  | 12-046 |  | 12-054 |  |  | 24273007 | 13-002F | EJ | 13-015 | PR | OB-2 |  |  |  |  |
| 24273012a |  | Wave Solder of Torus and Solenoid Magnets Travel FY14 | 99d | 2013-12-03 | 2014-05-01 | 24273012 |  |  |  |  | 409d | 502d | 8/5 M-F w/JLAB Holidays ReBaseline | MECH TECH [197.43 h]; SCIENTIST [98.72 h]; TRAVEL | 29,027.18 |  |  |  |  |  |  | 0 | ELOUADRHIRI L | 1 | 1 | S | LATIFA E |  | 12-024 | ST | 12-046 |  |  |  |  | 24273012 | 13-002F |  | 13-015 | PR |  |  | PE | PE | 14-001 |

Notes:
- 14273000: Steps: Soldering Machine Design (done); Procurement Prep (done); Space Preperation (done); (New step) (done)
- 14273011: Explanation: 7 trips - / 0.6w/trip MT / 0.3w/trip scientist / $1,400.00/trip expenses / Steps: Trip 1 (done); Trip 2 (done); Trip 3 (done); Trip 4 (done); Trip 5 (done); Trip 6 (done); Trip 7 (done)
- 14273012: Explanation: 24 trips - / 0.6w/trip MT / 0.3w/trip scientist / $1,400.00/trip expenses / Steps: Trip 1 (done); Trip 2 (done); Trip 3 (done); Trip 4 (done); Trip 5 (done); Trip 6 (done); Trip 7 (done); Trip 8 (done); Trip 9 (done); Trip 10 (done); Trip 11 (done); Trip 12 (done); Trip 13 (done); Trip 14 (done); Trip 15 (done); Trip 16 (done); Trip 17 (done); Trip 18 (done); Trip 19 (done); Trip 20 (done); Trip 21 (done); Trip 22 (done); Trip 23 (done); Trip 24 (done)
- 24273012: Explanation: 24 trips - / 0.6w/trip MT / 0.3w/trip scientist / $1,400.00/trip expenses / Steps: Trip 15 (done); Trip 16 (done); Trip 17 (done); Trip 18 (done); Trip 19; Trip 20; Trip 21; Trip 22; Trip 23; Trip 24
- 24273022: Explanation: 24 trips - / 0.6w/trip MT / 0.3w/trip scientist / $1,400.00/trip expenses
- 24273012a: Explanation: 24 trips - / 0.6w/trip MT / 0.3w/trip scientist / $1,400.00/trip expenses / Steps: Trip 15; Trip 16; Trip 17; Trip 18; Trip 19; Trip 20; Trip 21; Trip 22; Trip 23; Trip 24

| ID | WBS | Activity | Type | Duration | Start | Finish | Predecessors | Complete | Remaining | Planned start | Planned finish | Total float | Free float | Calendar | Resources | Cost | Actual cost | Remaining Material Cost Based on % Compl | Claimed Material Cost Based on % Complet | Initial Claimed Material Calc | Claimed Material Divider | MONTHLY EV COST | ReBaseline Actuals Adjustment | Original Activity ID Rebaseline | PRIOR MONTH EV COST | RESP - Responsibility | STRT%COMP for CM EVM | FNSH%COMP for CM EVM | EVMS Reporting Codes | CAM RESPONSIBLE | 12 GEV MAJOR PROCUREMENT CATAGORY | CR 12-024 | CR 13-002 | BOE Labor | CR 13-015 | Post Rebaseline | Activities with Steps | CR 14-001 | BOE Procurement | Obligated Prior to Rebaseline | CR 12-042 | BOE Expenses | LOE % Pre Calc | LOE % | LOE Divider | LOE Multiplier |
| --- | --- | --- | --- | --- | --- | --- | --- | --- | --- | --- | --- | --- | --- | --- | --- | --- | --- | --- | --- | --- | --- | --- | --- | --- | --- | --- | --- | --- | --- | --- | --- | --- | --- | --- | --- | --- | --- | --- | --- | --- | --- | --- | --- | --- | --- | --- |
|  | 4 | **1.4.2.7.4 TORUS CRYOSTAT FACTORY** |  |  | 2013-08-30 | 2015-08-14 |  |  |  |  |  |  |  |  |  |  |  |  |  |  |  |  |  |  |  |  |  |  |  |  |  |  |  |  |  |  |  |  |  |  |  |  |  |  |  |  |
|  | 1 | **1.4.2.7.4.1 DESIGN AND PROCEDURES** |  |  | 2013-08-30 | 2014-09-30 |  |  |  |  |  |  |  |  |  |  |  |  |  |  |  |  |  |  |  |  |  |  |  |  |  |  |  |  |  |  |  |  |  |  |  |  |  |  |  |  |
| 142741000 |  | Re-Baseline Actuals Adjustment |  | 1d | 2013-08-30 A | 2013-08-30 A |  | 100% |  | 2013-09-03 | 2013-09-03 |  |  |  | PROCUREMENT>$50K 69 NO ESCALATION | 122,695.66 |  | 0 | 122695.66 | 12269566 | 100 | 122695.66 | ADJ |  |  |  |  |  |  |  |  |  |  |  |  |  |  |  |  |  |  |  |  |  |  |  |
| 242741010 |  | Cryostat Factory - Design lifting Fixtures and Procurement Prep (Historical) |  | 3d | 2013-09-03 A | 2013-09-06 A | 9-130M FS+228d | 100% |  | 2013-10-01 | 2013-10-03 |  |  | 8/5 M-F w/JLAB Holidays ReBaseline | MECH ENG [45.7 h]; MECH DES [27.57 h] | 4,826.65 | 4,677.25 |  |  |  |  | 0 |  | 24271745 | 4677.249543 | ELOUADRHIRI L | 1 | 1 | H | LATIFA E | 4211 | 12-024 | 13-002F | EJ | 13-015 | PR |  |  |  |  |  |  |  |  |  |  |
| 242741020 |  | Cryostat Factory - Perform tests for Torus Design - labor |  | 10d | 2013-09-03 A | 2013-09-14 A | 9-130M FS+228d | 100% |  | 2013-10-01 | 2013-10-14 |  |  | 8/5 M-F w/JLAB Holidays ReBaseline | MECH ENG [3.9 h]; MECH TECH [3.9 h] | 476.37 | 461.65 |  |  |  |  | 0 |  | 24271770 | 461.6491 | ELOUADRHIRI L | 1 | 1 | H | LATIFA E | 4211 | 12-024 | 13-002F | EJ | 13-015 | PR |  |  |  |  |  |  |  |  |  |  |
| 242741030 |  | Cryostat Factory - Write, review and sign welding Procedures |  | 10d | 2013-09-03 A | 2013-10-21 A | 9-130M FS+228d | 100% |  | 2013-10-01 | 2013-10-14 |  |  | 8/5 M-F w/JLAB Holidays ReBaseline | SR STAFF [1.59 h]; MECH ENG [4.78 h] | 548.35 | 541.42 |  |  |  |  | 265.6927 |  | 24271780 | 265.6927 | ELOUADRHIRI L | 1 | 1 | H | LATIFA E | 4211 | 12-024 | 13-002F | EJ | 13-015 | PR |  |  |  |  |  |  |  |  |  |  |
| 242741035 |  | Cryostat Factory - Write, review and sign Incoming material QA Procedures FY13 |  | 20d | 2013-09-03 A | 2013-10-21 A | 9-130M FS+228d | 100% |  | 2013-10-01 | 2013-10-28 |  |  | 8/5 M-F w/JLAB Holidays ReBaseline | SR STAFF [4.98 h]; MECH ENG [19.91 h] | 2,085.78 | 2,065.76 |  |  |  |  | 2021.26712 |  | 24271785 |  | ELOUADRHIRI L | 1 | 1 | S | LATIFA E | 4211 | 12-024 | 13-002F | EJ | 13-015 | PR | ST |  |  |  |  |  |  |  |  |  |
| 242741035a |  | Cryostat Factory - Write, review and sign Incoming material QA Procedures FY14 |  | 12d | 2013-09-03 A | 2013-10-21 A | 242741035 FS-20d | 100% |  | 2013-10-01 | 2013-10-16 |  |  | 8/5 M-F w/JLAB Holidays ReBaseline | SR STAFF [2.99 h]; MECH ENG [11.94 h] | 1,251.14 | 1,237.07 |  |  |  |  | 1251.134 |  | 24271785 |  | ELOUADRHIRI L | 1 | 1 | S | LATIFA E | 4211 | 12-024 | 13-002F | EJ | 13-015 | PR | ST | 14-001 |  |  |  |  |  |  |  |  |
| 242741040 |  | Cryostat Factory - Write, review and sign material handling Procedures FY13 |  | 20d | 2013-09-03 A | 2013-10-21 A | 9-130M FS+228d | 100% |  | 2013-10-01 | 2013-10-28 |  |  | 8/5 M-F w/JLAB Holidays ReBaseline | MECH ENG [1.99 h]; SR STAFF [0.99 h] | 267.86 | 264.85 |  |  |  |  | 129.788926 |  | 24271790 | 129.788926 | ELOUADRHIRI L | 1 | 1 | H | LATIFA E | 4211 | 12-024 | 13-002F | EJ | 13-015 | PR |  |  |  |  |  |  |  |  |  |  |
| 242741040a |  | Cryostat Factory - Write, review and sign material handling Procedures FY14 |  | 12d | 2013-09-03 A | 2013-10-21 A | 242741040 FS-20d | 100% |  | 2013-10-01 | 2013-10-16 |  |  | 8/5 M-F w/JLAB Holidays ReBaseline | MECH ENG [1.19 h]; SR STAFF [0.6 h] | 160.9 | 159.08 |  |  |  |  | 80.448574 |  | 24271790 | 80.448574 | ELOUADRHIRI L | 1 | 1 | H | LATIFA E | 4211 | 12-024 | 13-002F | EJ | 13-015 | PR |  | 14-001 |  |  |  |  |  |  |  |  |
| 242741045 |  | Cryostat Factory - Write, review and sign MLI application Procedures |  | 10d | 2013-09-03 A | 2013-09-14 A | 9-130M FS+228d | 100% |  | 2013-10-01 | 2013-10-14 |  |  | 8/5 M-F w/JLAB Holidays ReBaseline | MECH ENG [3.18 h]; SR STAFF [1.59 h] | 428.76 | 415.49 |  |  |  |  | 0 |  | 24271795 | 415.4988 | ELOUADRHIRI L | 1 | 1 | H | LATIFA E | 4211 | 12-024 | 13-002F | EJ | 13-015 | PR |  |  |  |  |  |  |  |  |  |  |
| 242741050 |  | Cryostat Factory - Write, review and sign OSP FY13 |  | 20d | 2013-09-03 A | 2013-11-26 | 9-130M FS+228d | 33% | 18d | 2013-10-01 | 2013-10-28 | 141d | 0d | 8/5 M-F w/JLAB Holidays ReBaseline | MECH ENG [5.31 h]; SR STAFF [1.77 h] | 609.47 | 423.45 |  |  |  |  | 194.902488 |  | 24271800 |  | ELOUADRHIRI L | 1 | 1 | S | LATIFA E | 4211 | 12-024 | 13-002F | EJ | 13-015 | PR | ST |  |  |  |  |  |  |  |  |  |
| 242741050a |  | Cryostat Factory - Write, review and sign OSP FY14 |  | 34d | 2013-09-03 A | 2013-11-26 | 242741050 FS-40d | 33% | 18d | 2013-10-01 | 2013-11-15 | 141d | 0d | 8/5 M-F w/JLAB Holidays ReBaseline | MECH ENG [9.02 h]; SR STAFF [3.01 h] | 1,035.57 | 719.5 |  |  |  |  | 341.73891675 |  | 24271800 |  | ELOUADRHIRI L | 1 | 1 | S | LATIFA E | 4211 | 12-024 | 13-002F | EJ | 13-015 | PR | ST | 14-001 |  |  |  |  |  |  |  |  |
| 242741055 |  | Cryostat Factory - Write, review and sign assembly procedures FY13 |  | 20d | 2013-09-03 A | 2013-11-18 | 9-130M FS+228d |  | 12d | 2013-10-01 | 2013-10-28 | 147d | 6d | 8/5 M-F w/JLAB Holidays ReBaseline | MECH ENG [7.47 h]; SR STAFF [1.49 h] | 737.22 | 446.51 |  |  |  |  | 0 |  | 24271805 |  | ELOUADRHIRI L | 1 | 1 | S | LATIFA E | 4211 | 12-024 | 13-002F | EJ | 13-015 | PR | ST |  |  |  |  |  |  |  |  |  |
| 242741055a |  | Cryostat Factory - Write, review and sign assembly procedures FY14 |  | 12d | 2013-09-03 A | 2013-11-18 | 242741055 FS-20d |  | 12d | 2013-10-01 | 2013-10-16 | 147d | 6d | 8/5 M-F w/JLAB Holidays ReBaseline | MECH ENG [4.47 h]; SR STAFF [0.9 h] | 441.84 | 267.6 |  |  |  |  | 0 |  | 24271805 |  | ELOUADRHIRI L | 1 | 1 | S | LATIFA E | 4211 | 12-024 | 13-002F | EJ | 13-015 | PR | ST | 14-001 |  |  |  |  |  |  |  |  |
| 242741065 |  | Cryostat Factory - Orderfixtures, tables, tools, etc. for assembly Procurement |  | 32d | 2013-09-03 A | 2014-09-30 | 9-130M FS+228d | 95% | 224d | 2013-10-01 | 2013-11-13 | 208d | 24d | 8/5 M-F w/JLAB Holidays ReBaseline | PROCUREMENT<$50K 60 NO ESCALATION FY14 | 37,877 |  | 1893.85 | 35983.15 | 3598315 | 100 | 33331.76 |  | 24271815 | 2651.39 | ELOUADRHIRI L | 1 | 1 | D | LATIFA E | 4211 | 12-024 | 13-002F |  | 13-015 | PR | NB |  | EV | OB |  |  |  |  |  |  |
| 242741070 |  | Cryostat Stand and Axle |  | 42d | 2013-09-03 A | 2013-10-21 A | 9-130M FS+228d | 100% |  | 2013-10-01 | 2013-11-27 |  |  | 8/5 M-F w/JLAB Holidays ReBaseline | PROCUREMENT<$50K 60 NO ESCALATION FY14 | 5,814.28 |  | 0 | 5814.28 | 581428 | 100 | 2907.14 |  | 24271815 | 2907.14 | ELOUADRHIRI L | 1 | 1 | D | LATIFA E | 4211 | 12-024 | 13-002F |  | 13-015 | PR |  |  | EV | OB |  |  |  |  |  |  |
| 242741070M |  | Cryostat factory fixtures and tooling in-house | milestone | 0d | 2013-11-01 | 2013-11-01 | 242741065 FS-248d, 242741070 |  |  |  |  | 184d | 25d | 8/5 M-F w/JLAB Holidays ReBaseline |  |  |  |  |  |  |  | 0 |  | 24271820M |  | ELOUADRHIRI L | 1 | 1 | M | LATIFA E | 4211 |  | 13-002F |  | 13-015 | PR |  |  |  |  | 12-042 |  |  |  |  |  |
| 242741075M |  | Torus Cryostat Factory Procedures In-place | milestone | 0d | 2013-11-26 | 2013-11-26 | 242741055a, 242741040, 242741055, 242741035a, 242741030, 242741035, 242741045, 242741050, 242741050a, 242741010, 242741040a, 242741020 |  |  |  |  | 141d | 77d | 8/5 M-F w/JLAB Holidays ReBaseline |  |  |  |  |  |  |  | 0 |  | 24271830M |  | ELOUADRHIRI L | 1 | 1 | M | LATIFA E | 4211 |  | 13-002F |  | 13-015 | PR |  |  |  |  | 12-042 |  |  |  |  |  |
|  | 2 | **1.4.2.7.4.2 PROTOTYPE** |  |  | 2013-09-03 | 2014-06-16 |  |  |  |  |  |  |  |  |  |  |  |  |  |  |  |  |  |  |  |  |  |  |  |  |  |  |  |  |  |  |  |  |  |  |  |  |  |  |  |  |
| 242742000 |  | Cryostat Factory - Test Lifting Fixtures and Procedures with Wang Coil Case FY13 |  | 20d | 2013-09-03 A | 2013-10-21 A | 9-130M FS+228d | 100% |  | 2013-10-01 | 2013-10-28 |  |  | 8/5 M-F w/JLAB Holidays ReBaseline | MECH TECH [43.75 h]; MECH ENG [196.88 h]; SUPPLIES & MATERIALS | 18,958.75 | 16,604.47 |  |  |  |  | 5532.0263136 |  | 24271835 | 12908.0613984 | ELOUADRHIRI L | 1 | 1 | S | LATIFA E | 4211 | 12-024 | 13-002F | EJ | 13-015 | PR | ST |  |  |  |  | EJ |  |  |  |  |
| 242742015 |  | Cryostat Factory - Test Lifting Fixtures and Procedures with Wang Coil Case FY14 |  | 12d | 2013-09-03 A | 2013-10-21 A | 242742000 FS-20d | 100% |  | 2013-10-01 | 2013-10-16 |  |  | 8/5 M-F w/JLAB Holidays ReBaseline | MECH TECH [26.25 h]; MECH ENG [118.13 h]; SUPPLIES & MATERIALS | 11,417.26 | 9,949.73 |  |  |  |  | 3425.1786717 |  | 24271835 | 7992.0835673 | ELOUADRHIRI L | 1 | 1 | S | LATIFA E | 4211 | 12-024 | 13-002F | EJ | 13-015 | PR | ST | 14-001 |  |  |  | EJ |  |  |  |  |
| 242742020 |  | Cryostat Factory - Engineering oversight (Legg) FY13 |  | 20d | 2013-09-03 A | 2013-09-30 A | 9-130M FS+228d | 100% |  | 2013-10-01 | 2013-10-28 |  |  | 8/5 M-F w/JLAB Holidays ReBaseline | SR STAFF [168.07 h] | 20,222.18 | 19,596.96 |  |  |  |  | 0 |  | 24271850M | 19596.962 | ELOUADRHIRI L | 1 | 1 | E | LATIFA E | 4211 |  | 13-002F |  | 13-015 | PR |  |  |  |  | 12-042 |  | 83.19327731 | 16.80672268 | 100 | 100 |
| 242742030 |  | Cryostat Factory - Pre-assembly of CCM using Wang Coil case FY13 |  | 20d | 2013-09-03 A | 2013-10-21 A | 9-130M FS+228d | 100% |  | 2013-10-01 | 2013-10-28 |  |  | 8/5 M-F w/JLAB Holidays ReBaseline | MECH TECH [192 h]; MECH ENG [64 h] | 13,864.32 | 13,761.92 |  |  |  |  | 13436.16 |  | 24271850M |  | ELOUADRHIRI L | 1 | 1 | S | LATIFA E | 4211 |  | 13-002F |  | 13-015 | PR | ST |  |  |  | 12-042 |  |  |  |  |  |
| 242742030a |  | Cryostat Factory - Pre-assembly of CCM using Wang Coil case FY14 |  | 22.5d | 2013-09-03 A | 2013-11-26 | 242742030 FS-25d | 80% | 17.5d | 2013-10-01 | 2013-10-31 | 510.5d | 603.5d | 8/5 M-F w/JLAB Holidays ReBaseline | MECH TECH [216 h]; MECH ENG [72 h] | 15,597.36 | 10,926.5 |  |  |  |  | 12477.888 |  | 24271850M |  | ELOUADRHIRI L | 1 | 1 | S | LATIFA E | 4211 |  | 13-002F |  | 13-015 | PR | ST | 14-001 |  |  | 12-042 |  |  |  |  |  |
| 242742005 |  | Cryostat Factory - Layout Assembly area for equipment and fixtures |  | 5d | 2013-09-16 A | 2013-11-11 | 242741070M FS-25d | 40% | 7d | 2013-10-03 | 2013-10-09 | 162d | 3d | 8/5 M-F w/JLAB Holidays ReBaseline | MECH TECH [24 h]; MECH ENG [96 h]; SR STAFF [40 h] | 13,116.8 | 7,767.95 |  |  |  |  | 0 |  | 24271840 | 5246.72 | ELOUADRHIRI L | 1 | 1 | S | LATIFA E | 4211 | 12-024 | 13-002F | EJ | 13-015 | PR | ST | 14-001 |  |  |  |  |  |  |  |  |
| 242742010 |  | Cryostat Factory - Install equipment and fixtures in factory area |  | 24d | 2013-09-16 A | 2013-10-21 A | 242741070M FS-25d, 242742005 FS-10d | 100% |  | 2013-10-03 | 2013-11-05 |  |  | 8/5 M-F w/JLAB Holidays ReBaseline | MECH TECH [512 h]; MECH ENG [256 h]; SR STAFF [128 h]; SUPPLIES & MATERIALS | 61,220.88 | 58,411.55 |  |  |  |  | 36732.528 |  | 24271845 | 24488.352 | ELOUADRHIRI L | 1 | 1 | S | LATIFA E | 4211 | 12-024 | 13-002F | EJ | 13-015 | PR | ST | 14-001 |  |  |  | EJ |  |  |  |  |
| 242742025 |  | Cryostat Factory - Mock-up of one quarter CCM |  | 66d | 2013-09-16 A | 2014-03-03 | 9-140M FS-5d |  | 76d | 2013-10-04 | 2014-01-17 | 452d | 545d | 8/5 M-F w/JLAB Holidays ReBaseline | MECH TECH [520 h]; MECH ENG [200 h] | 39,540.4 | 12,099.45 |  |  |  |  | 0 |  | 24271850M |  | ELOUADRHIRI L | 1 | 1 | S | LATIFA E | 4211 |  | 13-002F |  | 13-015 | PR | ST | 14-001 |  |  | 12-042 |  |  |  |  |  |
| 242742020a |  | Cryostat Factory - Engineering oversight (Legg) FY14 |  | 99d | 2013-10-01 A | 2014-03-03 | 242742020 | 23% | 76d | 2013-11-01 | 2014-04-03 | 452d | 545d | 8/5 M-F w/JLAB Holidays ReBaseline | SR STAFF [831.93 h] | 100,097.82 | 23,255.05 |  |  |  |  | 23252.72302848 |  | 24271850M |  | ELOUADRHIRI L | 1 | 1 | E | LATIFA E | 4211 |  | 13-002F |  | 13-015 | PR |  | 14-001 |  |  | 12-042 |  | 76.76767676 | 23.23232323 | 100 | 100 |
| 242742080 |  | Cryostat Factory - Rewrite procedures and lessons learned from Proto |  | 88d | 2013-10-17 A | 2014-03-04 | 242742000 FS-40d, 242742015 FS-40d | 12% | 77d | 2013-11-19 | 2014-04-04 | 132d | 62d | 8/5 M-F w/JLAB Holidays ReBaseline | SR STAFF [160 h]; MECH ENG [480 h] | 55,092.8 | 6,886.6 |  |  |  |  | 6886.6 |  | 24271865 |  | ELOUADRHIRI L | 1 | 1 | E | LATIFA E | 4211 | 12-024 | 13-002F | EJ | 13-015 | PR |  | 14-001 |  |  |  |  | 87.5 | 12.5 | 100 | 100 |
| 242742040 |  | Cryostat Factory - Initial receipt inspection (QA) of Coil case shields |  | 77d | 2013-11-01 | 2014-03-04 | 242751115 FS-85d |  |  |  |  | 125d | 0d | 8/5 M-F w/JLAB Holidays ReBaseline | MECH TECH [60 h]; MECH ENG [60 h] | 7,319.4 |  |  |  |  |  | 0 |  | 24271850M |  | ELOUADRHIRI L | 1 | 1 | S | LATIFA E | 4211 |  | 13-002F |  | 13-015 | PR | ST | 14-001 |  |  | 12-042 |  |  |  |  |  |
| 242742045 |  | Cryostat Factory - Pre-Assemble Seven Coil case shields |  | 86d | 2013-11-01 | 2014-03-17 | 242742040 FS-77d |  |  |  |  | 125d | 61d | 8/5 M-F w/JLAB Holidays ReBaseline | MECH TECH [700 h]; MECH ENG [700 h] | 85,393 |  |  |  |  |  | 0 |  | 24271850M |  | ELOUADRHIRI L | 1 | 1 | S | LATIFA E | 4211 |  | 13-002F |  | 13-015 | PR | ST | 14-001 |  |  | 12-042 |  |  |  |  |  |
| 242742050 |  | Cryostat Factory - Initial receipt inspection (QA) of Vacuum Vessel Parts |  | 80d | 2013-11-25 | 2014-03-31 | 242751090 FS-86d |  |  |  |  | 59d | 0d | 8/5 M-F w/JLAB Holidays ReBaseline | MECH TECH [120 h] | 5,678.4 |  |  |  |  |  | 0 |  | 24271850M |  | ELOUADRHIRI L | 1 | 1 | S | LATIFA E | 4211 |  | 13-002F |  | 13-015 | PR | ST | 14-001 |  |  | 12-042 |  |  |  |  |  |
| 242742055 |  | Cryostat Factory - Pre-Assemble Seven Vacuum Jackets |  | 118d | 2013-11-25 | 2014-05-22 | 242742050 FS-80d |  |  |  |  | 59d | 0d | 8/5 M-F w/JLAB Holidays ReBaseline | MECH TECH [1080 h]; MECH ENG [220 h] | 67,533 |  |  |  |  |  | 0 |  | 24271850M |  | ELOUADRHIRI L | 1 | 1 | S | LATIFA E | 4211 |  | 13-002F |  | 13-015 | PR | ST | 14-001 |  |  | 12-042 |  |  |  |  |  |
| 242742035 |  | Cryostat Factory - Initial reciept inspection of Coil Case MLI |  | 10d | 2014-02-17 | 2014-02-28 | 242751125 FS-10d |  |  |  |  | 101d | 37d | 8/5 M-F w/JLAB Holidays ReBaseline | MECH TECH [20 h]; MECH ENG [20 h] | 2,439.8 |  |  |  |  |  | 0 |  | 24271850M |  | ELOUADRHIRI L | 1 | 1 | S | LATIFA E | 4211 |  | 13-002F |  | 13-015 | PR | ST | 14-001 |  |  | 12-042 |  |  |  |  |  |
| 242742015M |  | Cryostat Factory - Receive parts for proto cryostat | milestone | 0d | 2014-02-28 | 2014-02-28 | 242751115 FS-30d, 242751125, 242751090 FS-30d, 242751145 |  |  |  |  | 118d | 59d | 8/5 M-F w/JLAB Holidays ReBaseline |  |  |  |  |  |  |  | 0 |  | 24271850M |  | ELOUADRHIRI L | 1 | 1 | M | LATIFA E | 4211 |  | 13-002F |  | 13-015 | PR |  |  |  |  | 12-042 |  |  |  |  |  |
| 242742060M |  | Cryostat Factory - Receive 1st Article (CCM #1) coil cold case | milestone | 0d | 2014-03-31 | 2014-03-31 | 24271680 FS-19d, 242711.3035 |  |  |  |  | 64d | 0d | 8/5 M-F w/JLAB Holidays ReBaseline |  |  |  |  |  |  |  | 0 |  | 24271855M |  | ELOUADRHIRI L | 1 | 1 | M | LATIFA E | 4211 |  | 13-002F |  | 13-015 | PR |  |  |  |  | 12-042 |  |  |  |  |  |
| 242742065 |  | Cryostat Factory - Assemble 1st Article (CCM #1) Coil Cryostat with cold mass (Receive, QA and Pre-assembly) |  | 17d | 2014-03-31 | 2014-04-22 | 242742010, 242741075M, 242742015, 242771010, 242742000, 242742060M |  |  |  |  | 64d | 0d | 8/5 M-F w/JLAB Holidays ReBaseline | MECH ENG [188.57 h]; SUPPLIES & MATERIALS; MECH TECH [597.14 h]; SR STAFF [94.29 h] | 57,122.24 |  |  |  |  |  | 0 |  | 24271860 |  | ELOUADRHIRI L | 1 | 1 | S | LATIFA E | 4211 | 12-024 | 13-002F | EJ | 13-015 | PR | ST | 14-001 |  |  |  | EJ |  |  |  |  |
| 242742070 |  | Cryostat Factory - Assemble 1st Article (CCM #1) Coil Cryostat with cold mass (MLI and LN2 shield assembly) |  | 17d | 2014-04-23 | 2014-05-15 | 242742065, 242742045 FS-35d, 242742035 |  |  |  |  | 64d | 5d | 8/5 M-F w/JLAB Holidays ReBaseline | SUPPLIES & MATERIALS; MECH TECH [760 h]; SR STAFF [120 h]; MECH ENG [240 h] | 71,761.72 |  |  |  |  |  | 0 |  | 24271862 |  | ELOUADRHIRI L | 1 | 1 | S | LATIFA E | 4211 | 12-024 | 13-002F | EJ | 13-015 | PR | ST | 14-001 |  |  |  | EJ |  |  |  |  |
| 242742075 |  | Cryostat Factory - Assemble 1st Article (CCM #1) Coil Cryostat with cold mass (Vac jacket weld up) |  | 16d | 2014-05-23 | 2014-06-16 | 242742055, 242742070, 242742015M |  |  |  |  | 59d | 34d | 8/5 M-F w/JLAB Holidays ReBaseline | SUPPLIES & MATERIALS; MECH TECH [651.43 h]; SR STAFF [102.86 h]; MECH ENG [205.71 h] | 62,001.38 |  |  |  |  |  | 0 |  | 24271863 |  | ELOUADRHIRI L | 1 | 1 | S | LATIFA E | 4211 | 12-024 | 13-002F | EJ | 13-015 | PR | ST | 14-001 |  |  |  | EJ |  |  |  |  |

Notes:
- 242741035: Steps: Write initial reciept inspection for LN2 shield (done); Write initial receipt inspection for vacuum jacket parts (done)
- 242741035a: Steps: Write initial reciept inspection for LN2 shield (done); Write initial receipt inspection for vacuum jacket parts (done)
- 242741050: Steps: Complete sub-OSPs for OSP (done); Obtain review signatures for OSP; Obtain Signatures for OSP
- 242741050a: Steps: Complete sub-OSPs for OSP (done); Obtain review signatures for OSP; Obtain Signatures for OSP
- 242741055: Steps: Add instrumentation installation to assembly procedure; Re-write Shield sub-assembly procedure
- 242741055a: Steps: Add instrumentation installation to assembly procedure; Re-write Shield sub-assembly procedure
- 242741065: Explanation: Treat as LOE Based on Progress Dates
- 242742000: Steps: Fit steel and cooling tubes into CCM (done); Lift with Lifting fixture (done)
- 242742015: Steps: Fit steel and cooling tubes into CCM (done); Lift with Lifting fixture (done)
- 242742030: Steps: Install bumpers and IPS (done); Install Instrumentation and Quench heater (done); Install MLI (done)
- 242742030a: Steps: Install bumpers and IPS (done); Install Instrumentation and Quench heater (done); Install MLI
- 242742005: Steps: Physical utilities layout and facilites request complete; Assembly Tables delivered (done)
- 242742010: Steps: Install Welding tables (done); Install rotation fixture (done); Move tooling and weld stations to factory area (done)
- 242742025: Steps: Drawings released; Procure / fab parts; Assemble CCM sub-assembly; Assemble Shield and P tube sub-assembly
- 242742040: Steps: Verify part count to drawing; Inspect parts for dimensionality; Clean and degrease Al pieces; Inpect LN2 coupler components; Inspect LN2 Shield MLI
- 242742045: Steps: Glue and screw aluminum plates together with G10 joint; Weld P tube to plate assemblies; Weld coupler onto P tube and leak check welds; Glue Al support tubes into shield back
- 242742050: Steps: Verify part count to drawing; Inspect parts for dimensionality; Clean and degrease SS pieces
- 242742055: Steps: Assemble back, sides and stay bars and tack together; Apply welds for warage correction; Assemble front VJ plate and tack together; Clamp and weld Sides to VJ backs; remove VJ front plate and clean out tray; Straighten and seal for storage
- 242742035: Steps: Measure dimensions of piece; Examine blanket for flaws, debris, etc.
- 242742065: Steps: Initial receipt inspection (CP-Torus-CCM-INSP-COLD) of CCM; Install OOPS cups, bumpers and IPS; Install tube extensions of He cooling lines. Leak check and pressure test; Install Instrumentation and Quench heater; Install MLI
- 242742070: Steps: Assemble LN2 Shield onto CCM with Threaded Inserts and IPS; Weld P tube couplers and leak and pressure check; Glue in plugs on Al spacer tubes; Route conductors, He tubes and Instrumentation wiring through to Hex connection; Wrap MLI on LN2 shield and place MLI tubes in through holes
- 242742075: Steps: Lower CCM/LN2 shield assembly into vacuum jacket; Dress instrumentation, conductors and He lines into Hex ring connection point; Lift front vacuum jacket plate on assembly and weld in place; Lift and Weld upper vaccuum jacket in place; Straighten and weld on remaining side walls; Install OOPS supports and transport hardware. Ship to Hall B.

| ID | WBS | Activity | Type | Duration | Start | Finish | Predecessors | Complete | Planned start | Planned finish | Total float | Free float | Calendar | Resources | Cost | Remaining Material Cost Based on % Compl | Claimed Material Cost Based on % Complet | Initial Claimed Material Calc | Claimed Material Divider | MONTHLY EV COST | ReBaseline Actuals Adjustment | LOE % Pre Calc | LOE % | LOE Divider | LOE Multiplier | Original Activity ID Rebaseline | RESP - Responsibility | STRT%COMP for CM EVM | FNSH%COMP for CM EVM | EVMS Reporting Codes | CAM RESPONSIBLE | 12 GEV MAJOR PROCUREMENT CATAGORY | CR 12-024 | CR 13-002 | BOE Labor | CR 13-015 | Post Rebaseline | CR 14-001 | Activities with Steps | BOE Expenses | CR 12-042 | SC Magnet Dates |
| --- | --- | --- | --- | --- | --- | --- | --- | --- | --- | --- | --- | --- | --- | --- | --- | --- | --- | --- | --- | --- | --- | --- | --- | --- | --- | --- | --- | --- | --- | --- | --- | --- | --- | --- | --- | --- | --- | --- | --- | --- | --- | --- |
|  | 3 | **1.4.2.7.4.3 PRODUCTION** |  |  | 2013-08-30 | 2015-08-14 |  |  |  |  |  |  |  |  |  |  |  |  |  |  |  |  |  |  |  |  |  |  |  |  |  |  |  |  |  |  |  |  |  |  |  |  |
| 142743000 |  | Re-Baseline Actuals Adjustment |  | 1d | 2013-08-30 A | 2013-08-30 A |  | 100% | 2013-09-03 | 2013-09-03 |  |  |  | PROCUREMENT>$50K 69 NO ESCALATION | 29,404.61 | 0 | 29404.61 | 2940461 | 100 | 29404.61 | ADJ |  |  |  |  |  |  |  |  |  |  |  |  |  |  |  |  |  |  |  |  |  |
| 242743125 |  | Cryostat Factory - Rework |  | 306d | 2014-01-17 | 2015-04-10 | 242742060M FS-50d |  |  |  | 136d | 111d | 8/5 M-F w/JLAB Holidays ReBaseline | MECH ENG [320 h]; MECH TECH [1600 h]; SR STAFF [160 h] | 118,857.6 |  |  |  |  | 0 |  | 100 | 0 | 100 | 100 | 24271995 | ELOUADRHIRI L | 1 | 1 | E | LATIFA E | 4211 | 12-024 | 13-002F | EJ | 13-015 | PR | 14-001 |  |  |  |  |
| 242743005 |  | Cryostat Factory - Assemble Coil Cryostat #2 with cold mass (Receive, QA and Pre-assembly) |  | 22d | 2014-04-11 | 2014-05-12 | 242743000M FS-1d, 242742080 FS-35d |  |  |  | 70d | 0d | 8/5 M-F w/JLAB Holidays ReBaseline | MECH ENG [234.67 h]; SUPPLIES & MATERIALS; MECH TECH [528 h]; SR STAFF [117.33 h] | 66,944.07 |  |  |  |  | 0 |  |  |  |  |  | 24271875 | ELOUADRHIRI L | 1 | 1 | S | LATIFA E | 4211 | 12-024 | 13-002F | EJ | 13-015 | PR | 14-001 | ST | EJ |  |  |
| 242743000M |  | Cryostat Factory - Receive production coil case #2 | milestone | 0d | 2014-04-14 | 2014-04-14 | 242711.3040 |  |  |  | 70d | 0d | 8/5 M-F w/JLAB Holidays ReBaseline |  |  |  |  |  |  | 0 |  |  |  |  |  | 24271870M | ELOUADRHIRI L | 1 | 1 | M | LATIFA E | 4211 |  | 13-002F |  | 13-015 | PR |  |  |  | 12-042 |  |
| 242743020M |  | Cryostat Factory - Receive production coil case #3 | milestone | 0d | 2014-05-05 | 2014-05-05 | 242711.3045 |  |  |  | 77d | 6d | 8/5 M-F w/JLAB Holidays ReBaseline |  |  |  |  |  |  | 0 |  |  |  |  |  | 24271890M | ELOUADRHIRI L | 1 | 1 | M | LATIFA E | 4211 |  | 13-002F |  | 13-015 | PR |  |  |  | 12-042 |  |
| 242743010 |  | Cryostat Factory - Assemble Coil Cryostat #2 with cold mass (MLI and LN2 shield assembly) |  | 17d | 2014-05-13 | 2014-06-05 | 242743005 |  |  |  | 70d | 0d | 8/5 M-F w/JLAB Holidays ReBaseline | MECH TECH [560 h]; SR STAFF [80 h]; MECH ENG [160 h] | 48,072 |  |  |  |  | 0 |  |  |  |  |  | 24271880 | ELOUADRHIRI L | 1 | 1 | S | LATIFA E | 4211 | 12-024 | 13-002F | EJ | 13-015 | PR | 14-001 | ST |  |  |  |
| 242743025 |  | Cryostat Factory - Assemble Coil Cryostat #3 with cold mass (Receive, QA and Pre-assembly) |  | 17d | 2014-05-13 | 2014-06-05 | 242743020M, 242743005 |  |  |  | 71d | 0d | 8/5 M-F w/JLAB Holidays ReBaseline | SUPPLIES & MATERIALS; MECH TECH [704 h]; SR STAFF [58.67 h]; MECH ENG [117.33 h] | 59,452.33 |  |  |  |  | 0 |  |  |  |  |  | 24271895 | ELOUADRHIRI L | 1 | 1 | S | LATIFA E | 4211 | 12-024 | 13-002F | EJ | 13-015 | PR | 14-001 | ST | EJ |  |  |
| 242743015 |  | Cryostat Factory - Assemble Coil Cryostat #2 with cold mass (Vac jacket weld up) |  | 18d | 2014-06-06 | 2014-07-01 | 242743010, 242751375 FS-35d |  |  |  | 70d | 0d | 8/5 M-F w/JLAB Holidays ReBaseline | MECH TECH [300 h]; SR STAFF [33.33 h]; MECH ENG [66.67 h] | 23,184.67 |  |  |  |  | 0 |  |  |  |  |  | 24271885 | ELOUADRHIRI L | 1 | 1 | S | LATIFA E | 4211 | 12-024 | 13-002F | EJ | 13-015 | PR | 14-001 | ST |  |  |  |
| 242743030 |  | Cryostat Factory - Assemble Coil Cryostat #3 with cold mass (MLI and LN2 shield assembly) |  | 17d | 2014-06-06 | 2014-06-30 | 242743025, 242743010 |  |  |  | 71d | 0d | 8/5 M-F w/JLAB Holidays ReBaseline | MECH TECH [680 h]; SR STAFF [40 h]; MECH ENG [80 h] | 42,964 |  |  |  |  | 0 |  |  |  |  |  | 24271900 | ELOUADRHIRI L | 1 | 1 | S | LATIFA E | 4211 | 12-024 | 13-002F | EJ | 13-015 | PR | 14-001 | ST |  |  |  |
| 242743040M |  | Cryostat Factory - Receive production coil case #4 | milestone | 0d | 2014-06-10 | 2014-06-10 | 242711.3050 |  |  |  | 73d | 0d | 8/5 M-F w/JLAB Holidays ReBaseline |  |  |  |  |  |  | 0 |  |  |  |  |  | 24271910M | ELOUADRHIRI L | 1 | 1 | M | LATIFA E | 4211 |  | 13-002F |  | 13-015 | PR |  |  |  | 12-042 |  |
| 242743045 |  | Cryostat Factory - Assemble Coil Cryostat #4 with cold mass (Receive, QA and Pre-assembly) |  | 15d | 2014-06-10 | 2014-06-30 | 242743025, 242743040M |  |  |  | 73d | 0d | 8/5 M-F w/JLAB Holidays ReBaseline | SUPPLIES & MATERIALS; MECH TECH [704 h]; SR STAFF [58.67 h]; MECH ENG [117.33 h] | 59,452.33 |  |  |  |  | 0 |  |  |  |  |  | 24271915 | ELOUADRHIRI L | 1 | 1 | S | LATIFA E | 4211 | 12-024 | 13-002F | EJ | 13-015 | PR | 14-001 | ST | EJ |  |  |
| 242743050 |  | Cryostat Factory - Assemble Coil Cryostat #4 with cold mass (MLI and LN2 shield assembly) |  | 15d | 2014-07-01 | 2014-07-22 | 242743045, 242743030 |  |  |  | 73d | 3d | 8/5 M-F w/JLAB Holidays ReBaseline | MECH TECH [680 h]; SR STAFF [40 h]; MECH ENG [80 h] | 42,964 |  |  |  |  | 0 |  |  |  |  |  | 24271920 | ELOUADRHIRI L | 1 | 1 | S | LATIFA E | 4211 | 12-024 | 13-002F | EJ | 13-015 | PR | 14-001 | ST |  |  |  |
| 242743035 |  | Cryostat Factory - Assemble Coil Cryostat #3 with cold mass (Vac jacket weld up) |  | 17d | 2014-07-02 | 2014-07-25 | 242743030, 242743015 |  |  |  | 70d | 0d | 8/5 M-F w/JLAB Holidays ReBaseline | MECH TECH [300 h]; SR STAFF [33.33 h]; MECH ENG [66.67 h] | 23,184.67 |  |  |  |  | 0 |  |  |  |  |  | 24271905 | ELOUADRHIRI L | 1 | 1 | S | LATIFA E | 4211 | 12-024 | 13-002F | EJ | 13-015 | PR | 14-001 | ST |  |  |  |
| 242743060M |  | Cryostat Factory - Receive production coil case #5 | milestone | 0d | 2014-07-16 | 2014-07-16 | 242711.3055 |  |  |  | 63d | 0d | 8/5 M-F w/JLAB Holidays ReBaseline |  |  |  |  |  |  | 0 |  |  |  |  |  | 24271930M | ELOUADRHIRI L | 1 | 1 | M | LATIFA E | 4211 |  | 13-002F |  | 13-015 | PR |  |  |  | 12-042 |  |
| 242743065 |  | Cryostat Factory - Assemble Coil Cryostat #5 with cold mass (Receive, QA and Pre-assembly) |  | 15d | 2014-07-16 | 2014-08-05 | 242743045, 242743060M |  |  |  | 63d | 0d | 8/5 M-F w/JLAB Holidays ReBaseline | SUPPLIES & MATERIALS; MECH TECH [704 h]; SR STAFF [58.67 h]; MECH ENG [117.33 h] | 59,452.33 |  |  |  |  | 0 |  |  |  |  |  | 24271935 | ELOUADRHIRI L | 1 | 1 | S | LATIFA E | 4211 | 12-024 | 13-002F | EJ | 13-015 | PR | 14-001 | ST | EJ |  |  |
| 242743055 |  | Cryostat Factory - Assemble Coil Cryostat #4 with cold mass (Vac jacket weld up) |  | 15d | 2014-07-28 | 2014-08-15 | 242743035, 242743050 |  |  |  | 70d | 7d | 8/5 M-F w/JLAB Holidays ReBaseline | MECH TECH [300 h]; SR STAFF [33.33 h]; MECH ENG [66.67 h] | 23,184.67 |  |  |  |  | 0 |  |  |  |  |  | 24271925 | ELOUADRHIRI L | 1 | 1 | S | LATIFA E | 4211 | 12-024 | 13-002F | EJ | 13-015 | PR | 14-001 | ST |  |  |  |
| 242743070 |  | Cryostat Factory - Assemble Coil Cryostat #5 with cold mass (MLI and LN2 shield assembly) |  | 15d | 2014-08-06 | 2014-08-26 | 242743050, 242743065 |  |  |  | 63d | 0d | 8/5 M-F w/JLAB Holidays ReBaseline | MECH TECH [680 h]; SR STAFF [40 h]; MECH ENG [80 h] | 42,964 |  |  |  |  | 0 |  |  |  |  |  | 24271940 | ELOUADRHIRI L | 1 | 1 | S | LATIFA E | 4211 | 12-024 | 13-002F | EJ | 13-015 | PR | 14-001 | ST |  |  |  |
| 242743080M |  | Cryostat Factory - Receive production coil case #6 | milestone | 0d | 2014-08-12 | 2014-08-12 | 242711.3060 |  |  |  | 62d | 0d | 8/5 M-F w/JLAB Holidays ReBaseline |  |  |  |  |  |  | 0 |  |  |  |  |  | 24271950M | ELOUADRHIRI L | 1 | 1 | M | LATIFA E | 4211 |  | 13-002F |  | 13-015 | PR |  |  |  | 12-042 |  |
| 242743085 |  | Cryostat Factory - Assemble Coil Cryostat #6 with cold mass (Receive, QA and Pre-assembly) |  | 15d | 2014-08-12 | 2014-09-02 | 242743080M, 242743065 |  |  |  | 62d | 0d | 8/5 M-F w/JLAB Holidays ReBaseline | SUPPLIES & MATERIALS; MECH TECH [704 h]; SR STAFF [58.67 h]; MECH ENG [117.33 h] | 59,452.33 |  |  |  |  | 0 |  |  |  |  |  | 24271955 | ELOUADRHIRI L | 1 | 1 | S | LATIFA E | 4211 | 12-024 | 13-002F | EJ | 13-015 | PR | 14-001 | ST | EJ |  |  |
| 242743075 |  | Cryostat Factory - Assemble Coil Cryostat #5 with cold mass (Vac jacket weld up) |  | 15d | 2014-08-27 | 2014-09-17 | 242743070, 242743055 |  |  |  | 63d | 4d | 8/5 M-F w/JLAB Holidays ReBaseline | MECH TECH [300 h]; SR STAFF [33.33 h]; MECH ENG [66.67 h] | 23,184.67 |  |  |  |  | 0 |  |  |  |  |  | 24271945 | ELOUADRHIRI L | 1 | 1 | S | LATIFA E | 4211 | 12-024 | 13-002F | EJ | 13-015 | PR | 14-001 | ST |  |  |  |
| 242743090 |  | Cryostat Factory - Assemble Coil Cryostat #6 with cold mass (MLI and LN2 shield assembly) |  | 15d | 2014-09-03 | 2014-09-23 | 242743070, 242743085 |  |  |  | 62d | 0d | 8/5 M-F w/JLAB Holidays ReBaseline | MECH TECH [680 h]; SR STAFF [40 h]; MECH ENG [80 h] | 42,964 |  |  |  |  | 0 |  |  |  |  |  | 24271960 | ELOUADRHIRI L | 1 | 1 | S | LATIFA E | 4211 | 12-024 | 13-002F | EJ | 13-015 | PR | 14-001 | ST |  |  |  |
| 242743095 |  | Cryostat Factory - Assemble Coil Cryostat #6 with cold mass (Vac jacket weld up) |  | 15d | 2014-09-24 | 2014-10-14 | 242743090, 242743075 |  |  |  | 62d | 37d | 8/5 M-F w/JLAB Holidays ReBaseline | MECH TECH [300 h]; SR STAFF [33.33 h]; MECH ENG [66.67 h] | 23,184.67 |  |  |  |  | 0 |  |  |  |  |  | 24271965 | ELOUADRHIRI L | 1 | 1 | S | LATIFA E | 4211 | 12-024 | 13-002F | EJ | 13-015 | PR | 14-001 | ST |  |  | Y |
| 242743100M |  | Cryostat Factory - Receive production coil case #7 | milestone | 0d | 2015-05-13 | 2015-05-13 | 242751010, 242711.5030 |  |  |  | 49d | 0d | 8/5 M-F w/JLAB Holidays ReBaseline |  |  |  |  |  |  | 0 |  |  |  |  |  | 24271970M | ELOUADRHIRI L | 1 | 1 | M | LATIFA E | 4211 |  | 13-002F |  | 13-015 | PR |  |  |  | 12-042 |  |
| 242743105 |  | Cryostat Factory - Assemble Coil Cryostat #7 with cold mass (Receive, QA and Pre-assembly) |  | 15d | 2015-05-13 | 2015-06-04 | 242743085, 242743100M |  |  |  | 49d | 0d | 8/5 M-F w/JLAB Holidays ReBaseline | SUPPLIES & MATERIALS; MECH TECH [704 h]; SR STAFF [58.67 h]; MECH ENG [117.33 h] | 59,452.33 |  |  |  |  | 0 |  |  |  |  |  | 24271975 | ELOUADRHIRI L | 1 | 1 | S | LATIFA E | 4211 | 12-024 | 13-002F | EJ | 13-015 | PR | 14-001 | ST | EJ |  |  |
| 242743110 |  | Cryostat Factory - Assemble Coil Cryostat #7 with cold mass (MLI and LN2 shield assembly) |  | 15d | 2015-06-05 | 2015-06-25 | 242743090, 242743105 |  |  |  | 49d | 0d | 8/5 M-F w/JLAB Holidays ReBaseline | SR STAFF [40 h]; MECH ENG [80 h]; MECH TECH [680 h] | 42,964 |  |  |  |  | 0 |  |  |  |  |  | 24271980 | ELOUADRHIRI L | 1 | 1 | S | LATIFA E | 4211 | 12-024 | 13-002F | EJ | 13-015 | PR | 14-001 | ST |  |  |  |
| 242743120 |  | Cryostat Factory - Clean up And ship to site |  | 40d | 2015-06-19 | 2015-08-14 | 242743115 FS-20d |  |  |  | 49d | 24d | 8/5 M-F w/JLAB Holidays ReBaseline | MECH ENG [240 h]; MECH TECH [360 h]; SR STAFF [120 h] | 49,394.4 |  |  |  |  | 0 |  |  |  |  |  | 24271990 | ELOUADRHIRI L | 1 | 1 | U | LATIFA E | 4211 | 12-024 | 13-002F | EJ | 13-015 | PR | 14-001 |  |  |  |  |
| 242743115 |  | Cryostat Factory - Assemble Coil Cryostat #7 with cold mass (Vac jacket weld up) |  | 15d | 2015-06-26 | 2015-07-17 | 242743110, 242743095 |  |  |  | 49d | 0d | 8/5 M-F w/JLAB Holidays ReBaseline | MECH TECH [300 h]; SR STAFF [33.33 h]; MECH ENG [66.67 h] | 23,184.67 |  |  |  |  | 0 |  |  |  |  |  | 24271985 | ELOUADRHIRI L | 1 | 1 | S | LATIFA E | 4211 | 12-024 | 13-002F | EJ | 13-015 | PR | 14-001 | ST |  |  |  |

Notes:
- 242743005: Steps: Initial receipt inspection (CP-Torus-CCM-INSP-COLD) of CCM; Install OOPS cups, bumpers and IPS; Install tube extensions of He cooling lines. Leak check and pressure test; Install Instrumentation and Quench heater; Install MLI
- 242743010: Steps: Assemble LN2 Shield onto CCM with Threaded Inserts and IPS; Weld P tube couplers and leak and pressure check; Glue in plugs on Al spacer tubes; Route conductors, He tubes and Instrumentation wiring through to Hex connection; Wrap MLI on LN2 shield and place MLI tubes in through holes
- 242743025: Steps: Initial receipt inspection (CP-Torus-CCM-INSP-COLD) of CCM; Install OOPS cups, bumpers and IPS; Install tube extensions of He cooling lines. Leak check and pressure test; Install Instrumentation and Quench heater; Install MLI
- 242743015: Steps: Lower CCM/LN2 shield assembly into vacuum jacket; Dress instrumentation, conductors and He lines into Hex ring connection point; Lift front vacuum jacket plate on assembly and weld in place; Lift and Weld upper vaccuum jacket in place; Straighten and weld on remaining side walls; Install OOPS supports and transport hardware. Ship to Hall B.
- 242743030: Steps: Assemble LN2 Shield onto CCM with Threaded Inserts and IPS; Weld P tube couplers and leak and pressure check; Glue in plugs on Al spacer tubes; Route conductors, He tubes and Instrumentation wiring through to Hex connection; Wrap MLI on LN2 shield and place MLI tubes in through holes
- 242743045: Steps: Initial receipt inspection (CP-Torus-CCM-INSP-COLD) of CCM; Install OOPS cups, bumpers and IPS; Install tube extensions of He cooling lines. Leak check and pressure test; Install Instrumentation and Quench heater; Install MLI
- 242743050: Steps: Assemble LN2 Shield onto CCM with Threaded Inserts and IPS; Weld P tube couplers and leak and pressure check; Glue in plugs on Al spacer tubes; Route conductors, He tubes and Instrumentation wiring through to Hex connection; Wrap MLI on LN2 shield and place MLI tubes in through holes
- 242743035: Steps: Lower CCM/LN2 shield assembly into vacuum jacket; Dress instrumentation, conductors and He lines into Hex ring connection point; Lift front vacuum jacket plate on assembly and weld in place; Lift and Weld upper vaccuum jacket in place; Straighten and weld on remaining side walls; Install OOPS supports and transport hardware. Ship to Hall B.
- 242743065: Steps: Initial receipt inspection (CP-Torus-CCM-INSP-COLD) of CCM; Install OOPS cups, bumpers and IPS; Install tube extensions of He cooling lines. Leak check and pressure test; Install Instrumentation and Quench heater; Install MLI
- 242743055: Steps: Lower CCM/LN2 shield assembly into vacuum jacket; Dress instrumentation, conductors and He lines into Hex ring connection point; Lift front vacuum jacket plate on assembly and weld in place; Lift and Weld upper vaccuum jacket in place; Straighten and weld on remaining side walls; Install OOPS supports and transport hardware. Ship to Hall B.
- 242743070: Steps: Assemble LN2 Shield onto CCM with Threaded Inserts and IPS; Weld P tube couplers and leak and pressure check; Glue in plugs on Al spacer tubes; Route conductors, He tubes and Instrumentation wiring through to Hex connection; Wrap MLI on LN2 shield and place MLI tubes in through holes
- 242743085: Steps: Initial receipt inspection (CP-Torus-CCM-INSP-COLD) of CCM; Install OOPS cups, bumpers and IPS; Install tube extensions of He cooling lines. Leak check and pressure test; Install Instrumentation and Quench heater; Install MLI
- 242743075: Steps: Lower CCM/LN2 shield assembly into vacuum jacket; Dress instrumentation, conductors and He lines into Hex ring connection point; Lift front vacuum jacket plate on assembly and weld in place; Lift and Weld upper vaccuum jacket in place; Straighten and weld on remaining side walls; Install OOPS supports and transport hardware. Ship to Hall B.
- 242743090: Steps: Assemble LN2 Shield onto CCM with Threaded Inserts and IPS; Weld P tube couplers and leak and pressure check; Glue in plugs on Al spacer tubes; Route conductors, He tubes and Instrumentation wiring through to Hex connection; Wrap MLI on LN2 shield and place MLI tubes in through holes
- 242743095: Steps: Lower CCM/LN2 shield assembly into vacuum jacket; Dress instrumentation, conductors and He lines into Hex ring connection point; Lift front vacuum jacket plate on assembly and weld in place; Lift and Weld upper vaccuum jacket in place; Straighten and weld on remaining side walls; Install OOPS supports and transport hardware. Ship to Hall B.
- 242743105: Steps: Initial receipt inspection (CP-Torus-CCM-INSP-COLD) of CCM; Install OOPS cups, bumpers and IPS; Install tube extensions of He cooling lines. Leak check and pressure test; Install Instrumentation and Quench heater; Install MLI
- 242743110: Steps: Assemble LN2 Shield onto CCM with Threaded Inserts and IPS; Weld P tube couplers and leak and pressure check; Glue in plugs on Al spacer tubes; Route conductors, He tubes and Instrumentation wiring through to Hex connection; Wrap MLI on LN2 shield and place MLI tubes in through holes
- 242743115: Steps: Lower CCM/LN2 shield assembly into vacuum jacket; Dress instrumentation, conductors and He lines into Hex ring connection point; Lift front vacuum jacket plate on assembly and weld in place; Lift and Weld upper vaccuum jacket in place; Straighten and weld on remaining side walls; Install OOPS supports and transport hardware. Ship to Hall B.

| ID | WBS | Activity | Duration | Start | Finish | Predecessors | Complete | Remaining | Planned start | Planned finish | Total float | Free float | Calendar | Resources | Cost | Actual cost | Remaining Material Cost Based on % Compl | Claimed Material Cost Based on % Complet | Initial Claimed Material Calc | Claimed Material Divider | MONTHLY EV COST | ReBaseline Actuals Adjustment | LOE Divider | LOE Multiplier | Original Activity ID Rebaseline | PRIOR MONTH EV COST | RESP - Responsibility | STRT%COMP for CM EVM | FNSH%COMP for CM EVM | EVMS Reporting Codes | CAM RESPONSIBLE | 12 GEV MAJOR PROCUREMENT CATAGORY | Phil Dev | CR 12-024 | CR 13-002 | BOE Labor | CR 13-015 | Post Rebaseline | Obligated Prior to Rebaseline | BOE Procurement | CR 14-001 | Activities with Steps | LOE % Pre Calc | LOE % |
| --- | --- | --- | --- | --- | --- | --- | --- | --- | --- | --- | --- | --- | --- | --- | --- | --- | --- | --- | --- | --- | --- | --- | --- | --- | --- | --- | --- | --- | --- | --- | --- | --- | --- | --- | --- | --- | --- | --- | --- | --- | --- | --- | --- | --- |
|  | 5 | **1.4.2.7.5 TORUS MAGNET DESIGN/PARTS** |  | 2013-08-30 | 2014-10-21 |  |  |  |  |  |  |  |  |  |  |  |  |  |  |  |  |  |  |  |  |  |  |  |  |  |  |  |  |  |  |  |  |  |  |  |  |  |  |  |
|  | 1 | **1.4.2.7.5.1 TORUS MAGNET DESIGN/PARTS** |  | 2013-08-30 | 2014-10-21 |  |  |  |  |  |  |  |  |  |  |  |  |  |  |  |  |  |  |  |  |  |  |  |  |  |  |  |  |  |  |  |  |  |  |  |  |  |  |  |
| 142751000 |  | Re-Baseline Actuals Adjustment | 1d | 2013-08-30 A | 2013-08-30 A |  | 100% |  | 2013-09-03 | 2013-09-03 |  |  |  | PROCUREMENT>$50K 69 NO ESCALATION | 157,161.06 |  | 0 | 157161.06 | 15716106 | 100 | 157161.06 | ADJ |  |  |  |  |  |  |  |  |  |  |  |  |  |  |  |  |  |  |  |  |  |  |
| 242751000LOE |  | Torus - Engineering Oversight FY13 | 20d | 2013-09-03 A | 2013-09-30 A | 9-130M FS+228d | 100% |  | 2013-10-01 | 2013-10-28 |  |  | 8/5 M-F w/JLAB Holidays ReBaseline | SR STAFF [187.92 h] | 22,610.53 | 21,911.47 |  |  |  |  | 0 |  | 100 | 100 | 24271000LOE | 21911.472 | ELOUADRHIRI L | 1 | 1 | E | LATIFA E | 4211 | Phil | 12-024 | 13-002F | EJ | 13-015 | PR |  |  |  |  |  |  |
| 242751010 |  | Vend Fab Additional Coil Case for Coil # 7 | 139d | 2013-09-03 A | 2014-05-01 | 9-130M FS+228d |  | 119d | 2013-10-01 | 2014-04-28 | 303d | 254d | 8/5 M-F w/JLAB Holidays ReBaseline | PROCUREMENT<$50K 60 NO ESCALATION FY14 | 25,220 |  | 25220 | 0 | 0 | 100 | 0 |  |  |  | 24272180 |  | ELOUADRHIRI L | 1 | 1 | D | LATIFA E | 4211 |  | 12-024 | 13-002F | EJ | 13-015 | PR | OB |  |  |  |  |  |
| 242751020 |  | Torus - 1st Article Coil Case Procurement | 10d | 2013-09-03 A | 2013-09-16 A | 9-130M FS+228d | 100% |  | 2013-10-01 | 2013-10-14 |  |  | 8/5 M-F w/JLAB Holidays ReBaseline | PROCUREMENT<$50K 60 | 20,369.71 |  | 0 | 20369.71 | 2036971 | 100 | 0 |  |  |  | 24271024 | 20369.71 | ELOUADRHIRI L | 1 | 1 | D | LATIFA E | 4211 | Phil | 12-024 | 13-002F |  | 13-015 | PR | OB | VQ |  |  |  |  |
| 242751045 |  | Torus - 6 Production Coil Cases Procurement | 139d | 2013-09-03 A | 2014-05-01 | 9-130M FS+228d | 55% | 119d | 2013-10-01 | 2014-04-28 | 84d | 20d | 8/5 M-F w/JLAB Holidays ReBaseline | PROCUREMENT<$50K 60 NO ESCALATION FY14; PROCUREMENT>$50K 69 NO ESCALATION FY14 | 146,130.3 |  | 65758.635 | 80371.665 | 8037166.5 | 100 | 0 |  |  |  | 24271054 | 80371.665 | ELOUADRHIRI L | 1 | 1 | D | LATIFA E | 4211 | Phil | 12-024 | 13-002F |  | 13-015 | PR | OB | VQ |  |  |  |  |
| 242751050 |  | Torus - 4K MLI Modeling and Drafting | 10d | 2013-09-03 A | 2013-10-21 A | 9-130M FS+228d | 100% |  | 2013-10-01 | 2013-10-14 |  |  | 8/5 M-F w/JLAB Holidays ReBaseline | MECH DES [20 h] | 1,026 | 1,012.75 |  |  |  |  | 497.1 |  |  |  | 24271055 | 497.1 | ELOUADRHIRI L | 1 | 1 | H | LATIFA E | 4211 | Phil | 12-024 | 13-002F | EJ | 13-015 | PR |  |  |  |  |  |  |
| 242751080 |  | Torus - Vacuum Vessel Instrumentation Drafting | 20d | 2013-09-03 A | 2013-12-13 | 9-130M FS+228d | 50% | 29d | 2013-10-01 | 2013-10-28 | 70d | 11d | 8/5 M-F w/JLAB Holidays ReBaseline | MECH DES [21.6 h] | 1,108.08 | 652.23 |  |  |  |  | 0 |  |  |  | 24271090 | 536.868 | ELOUADRHIRI L | 1 | 1 | H | LATIFA E | 4211 | Phil | 12-024 | 13-002F | EJ | 13-015 | PR |  |  |  |  |  |  |
| 242751110 |  | Torus - Coil Case Shields Procurement Prep FY13 | 20d | 2013-09-03 A | 2013-10-21 A | 9-130M FS+228d | 100% |  | 2013-10-01 | 2013-10-28 |  |  | 8/5 M-F w/JLAB Holidays ReBaseline | MECH ENG [10.91 h] | 814.65 | 807.13 |  |  |  |  | 394.7238 |  |  |  | 24271112 | 394.7238 | ELOUADRHIRI L | 1 | 1 | H | LATIFA E | 4211 | Phil | 12-024 | 13-002F | EJ | 13-015 | PR |  |  |  |  |  |  |
| 242751110a |  | Torus - Coil Case Shields Procurement Prep FY14 | 24d | 2013-09-03 A | 2013-10-21 A | 242751110 FS-30d | 100% |  | 2013-10-29 | 2013-12-03 |  |  | 8/5 M-F w/JLAB Holidays ReBaseline | MECH ENG [13.09 h] | 977.43 | 968.4 |  |  |  |  | 488.71515 |  |  |  | 24271112 | 488.71515 | ELOUADRHIRI L | 1 | 1 | H | LATIFA E | 4211 | Phil | 12-024 | 13-002F | EJ | 13-015 | PR |  |  | 14-001 |  |  |  |
| 242751120 |  | Torus - Coil Case MLI Procurement Prep FY13 | 10d | 2013-09-03 A | 2013-11-15 | 242751050 FS-10d | 50% | 11d | 2013-10-08 | 2013-10-21 | 101d | 0d | 8/5 M-F w/JLAB Holidays ReBaseline | MECH ENG [9.09 h] | 678.75 | 532.71 |  |  |  |  | 0 |  |  |  | 24271116 | 328.8762 | ELOUADRHIRI L | 1 | 1 | H | LATIFA E | 4211 | Phil | 12-024 | 13-002F | EJ | 13-015 | PR |  |  |  |  |  |  |
| 242751120a |  | Torus - Coil Case MLI Procurement Prep FY14 | 34d | 2013-09-03 A | 2013-11-15 | 242751120 FS-35d | 50% | 11d | 2013-10-22 | 2013-12-10 | 101d | 0d | 8/5 M-F w/JLAB Holidays ReBaseline | MECH ENG [30.91 h] | 2,308.05 | 1,811.45 |  |  |  |  | 0 |  |  |  | 24271116 | 1154.02485 | ELOUADRHIRI L | 1 | 1 | H | LATIFA E | 4211 | Phil | 12-024 | 13-002F | EJ | 13-015 | PR |  |  | 14-001 |  |  |  |
| 242751155 |  | Torus - Cold Hub - Hub analysis with off design loads | 10d | 2013-09-03 A | 2013-09-23 A | 9-130M FS+228d | 100% |  | 2013-10-01 | 2013-10-14 |  |  | 8/5 M-F w/JLAB Holidays ReBaseline | MECH ENG [48 h] | 3,584.16 | 3,473.28 |  |  |  |  | 0 |  |  |  | 24271135 | 3473.28 | ELOUADRHIRI L | 1 | 1 | H | LATIFA E | 4211 | Phil | 12-024 | 13-002F | EJ | 13-015 | PR |  |  |  |  |  |  |
| 242751160 |  | Torus - Cold Hub - Hub Shield Modeling FY13 | 20d | 2013-09-03 A | 2013-11-15 | 242751155 FS-10d | 50% | 11d | 2013-10-01 | 2013-10-28 | 113d | 29d | 8/5 M-F w/JLAB Holidays ReBaseline | MECH ENG [7.11 h] | 530.9 | 416.67 |  |  |  |  | 0 |  |  |  | 24271140 | 257.2398 | ELOUADRHIRI L | 1 | 1 | H | LATIFA E | 4211 | Phil | 12-024 | 13-002F | EJ | 13-015 | PR |  |  |  |  |  |  |
| 242751160a |  | Torus - Cold Hub - Hub Shield Modeling FY14 | 34d | 2013-09-03 A | 2013-11-15 | 242751160 FS-40d | 50% | 11d | 2013-10-01 | 2013-11-15 | 113d | 43d | 8/5 M-F w/JLAB Holidays ReBaseline | MECH ENG [12.09 h] | 902.76 | 708.52 |  |  |  |  | 0 |  |  |  | 24271140 | 451.38015 | ELOUADRHIRI L | 1 | 1 | H | LATIFA E | 4211 | Phil | 12-024 | 13-002F | EJ | 13-015 | PR |  |  | 14-001 |  |  |  |
| 242751165 |  | Torus - Cold Hub - Hub Shield straping for cooling design FY13 | 20d | 2013-09-03 A | 2013-11-27 | 242751160a FS-54d, 242751160 FS-54d | 50% | 19d | 2013-10-01 | 2013-10-28 | 70d | 0d | 8/5 M-F w/JLAB Holidays ReBaseline | MECH ENG [2.58 h] | 192.65 | 131.69 |  |  |  |  | 0 |  |  |  | 24271145 | 93.3444 | ELOUADRHIRI L | 1 | 1 | H | LATIFA E | 4211 | Phil | 12-024 | 13-002F | EJ | 13-015 | PR |  |  |  |  |  |  |
| 242751165a |  | Torus - Cold Hub - Hub Shield straping for cooling design FY14 | 42d | 2013-09-03 A | 2013-11-27 | 242751165 FS-45d, 242751160a FS-54d | 50% | 19d | 2013-10-01 | 2013-11-27 | 70d | 0d | 8/5 M-F w/JLAB Holidays ReBaseline | MECH ENG [5.42 h] | 404.71 | 276.65 |  |  |  |  | 0 |  |  |  | 24271145 | 202.3557 | ELOUADRHIRI L | 1 | 1 | H | LATIFA E | 4211 | Phil | 12-024 | 13-002F | EJ | 13-015 | PR |  |  | 14-001 |  |  |  |
| 242751185 |  | Torus - Upstream Hex - 4K Beam Stress Analysis | 9d | 2013-09-03 A | 2013-10-21 A | 242751155 FS-10d | 100% |  | 2013-10-01 | 2013-10-11 |  |  | 8/5 M-F w/JLAB Holidays ReBaseline | MECH ENG [40 h] | 2,986.8 | 2,951.26 |  |  |  |  | 1447.2 |  |  |  | 24271155 | 1447.2 | ELOUADRHIRI L | 1 | 1 | H | LATIFA E | 4211 | Phil | 12-024 | 13-002F | EJ | 13-015 | PR |  |  |  |  |  |  |
| 242751190 |  | Torus - Upstream Hex - Piping mounting design FY13 | 10d | 2013-09-03 A | 2014-01-31 | 242751155 | 50% | 55d | 2013-10-15 | 2013-10-28 | 25d | 0d | 8/5 M-F w/JLAB Holidays ReBaseline | MECH DES [16 h] | 820.8 | 354.96 |  |  |  |  | 0 |  |  |  | 24271160 | 397.68 | ELOUADRHIRI L | 1 | 1 | H | LATIFA E | 4211 | Phil | 12-024 | 13-002F | EJ | 13-015 | PR |  |  |  |  |  |  |
| 242751190a |  | Torus - Upstream Hex - Piping mounting design FY14 | 15d | 2013-09-03 A | 2014-01-31 | 242751190 FS-60d | 50% | 55d | 2013-10-29 | 2013-11-18 | 25d | 0d | 8/5 M-F w/JLAB Holidays ReBaseline | MECH DES [24 h] | 1,231.2 | 532.43 |  |  |  |  | 0 |  |  |  | 24271160 | 615.6 | ELOUADRHIRI L | 1 | 1 | H | LATIFA E | 4211 | Phil | 12-024 | 13-002F | EJ | 13-015 | PR |  |  | 14-001 |  |  |  |
| 242751195 |  | Torus - Upstream Hex - Coil to Coil lead force analysis and flexibility analysis | 19d | 2013-09-03 A | 2013-09-16 A | 242751190 FS-80d, 242751185 FS-9d, 242751190a FS-80d | 100% |  | 2013-10-01 | 2013-10-25 |  |  | 8/5 M-F w/JLAB Holidays ReBaseline | MECH ENG [20 h] | 1,493.4 | 1,447.2 |  |  |  |  | 0 |  |  |  | 24271165 | 1447.2 | ELOUADRHIRI L | 1 | 1 | H | LATIFA E | 4211 | Phil | 12-024 | 13-002F | EJ | 13-015 | PR |  |  |  |  |  |  |
| 242751200 |  | Torus - Upstream Hex - Recooler final design FY13 | 20d | 2013-09-03 A | 2013-11-15 | 242751195 FS-60d | 50% | 11d | 2013-10-01 | 2013-10-28 | 95d | 0d | 8/5 M-F w/JLAB Holidays ReBaseline | MECH DES [25.45 h] | 1,305.59 | 1,024.65 |  |  |  |  | 0 |  |  |  | 24271170 | 632.55975 | ELOUADRHIRI L | 1 | 1 | H | LATIFA E | 4211 | Phil | 12-024 | 13-002F | EJ | 13-015 | PR |  |  |  |  |  |  |
| 242751200a |  | Torus - Upstream Hex - Recooler final design FY14 | 24d | 2013-09-03 A | 2013-11-15 | 242751200 FS-45d | 50% | 11d | 2013-10-01 | 2013-11-01 | 95d | 0d | 8/5 M-F w/JLAB Holidays ReBaseline | MECH DES [30.54 h] | 1,566.7 | 1,229.57 |  |  |  |  | 0 |  |  |  | 24271170 | 783.351 | ELOUADRHIRI L | 1 | 1 | H | LATIFA E | 4211 | Phil | 12-024 | 13-002F | EJ | 13-015 | PR |  |  | 14-001 |  |  |  |
| 242751205 |  | Torus - Upstream Hex - Recooler Mounting FY13 | 20d | 2013-09-03 A | 2013-11-15 | 242751200a FS-44d, 242751200 FS-44d | 50% | 11d | 2013-10-01 | 2013-10-28 | 72d | 0d | 8/5 M-F w/JLAB Holidays ReBaseline | MECH DES [6.55 h] | 336.02 | 263.71 |  |  |  |  | 0 |  |  |  | 24271175 | 162.80025 | ELOUADRHIRI L | 1 | 1 | H | LATIFA E | 4211 | Phil | 12-024 | 13-002F | EJ | 13-015 | PR |  |  |  |  |  |  |
| 242751205a |  | Torus - Upstream Hex - Recooler Mounting FY14 | 24d | 2013-09-03 A | 2013-11-15 | 242751205 FS-40d, 242751200a FS-44d | 50% | 11d | 2013-10-01 | 2013-11-01 | 72d | 0d | 8/5 M-F w/JLAB Holidays ReBaseline | MECH DES [7.85 h] | 402.71 | 316.05 |  |  |  |  | 0 |  |  |  | 24271175 | 201.3525 | ELOUADRHIRI L | 1 | 1 | H | LATIFA E | 4211 | Phil | 12-024 | 13-002F | EJ | 13-015 | PR |  |  | 14-001 |  |  |  |
| 242751215 |  | Torus - Upstream Hex - Splice design and tooling design FY13 | 20d | 2013-09-03 A | 2013-11-15 | 242751205a FS-44d, 242751205 FS-44d | 50% | 11d | 2013-10-01 | 2013-10-28 | 39d | 14d | 8/5 M-F w/JLAB Holidays ReBaseline | MECH DES [21.33 h] | 1,094.23 | 858.77 |  |  |  |  | 0 |  |  |  | 24271180 | 530.15715 | ELOUADRHIRI L | 1 | 1 | H | LATIFA E | 4211 | Phil | 12-024 | 13-002F | EJ | 13-015 | PR |  |  |  |  |  |  |
| 242751215a |  | Torus - Upstream Hex - Splice design and tooling design FY14 | 34d | 2013-09-03 A | 2013-11-15 | 242751215 FS-40d, 242751205a FS-44d | 50% | 11d | 2013-10-01 | 2013-11-15 | 39d | 14d | 8/5 M-F w/JLAB Holidays ReBaseline | MECH DES [36.27 h] | 1,860.65 | 1,460.27 |  |  |  |  | 0 |  |  |  | 24271180 | 930.3255 | ELOUADRHIRI L | 1 | 1 | H | LATIFA E | 4211 | Phil | 12-024 | 13-002F | EJ | 13-015 | PR |  |  | 14-001 |  |  |  |
| 242751220 |  | Torus - Upstream Hex - Piping flexibility analysis | 19d | 2013-09-03 A | 2013-09-23 A | 242751190a FS-35d, 242751190 FS-35d | 100% |  | 2013-10-01 | 2013-10-25 |  |  | 8/5 M-F w/JLAB Holidays ReBaseline | MECH ENG [28 h] | 2,090.76 | 2,026.08 |  |  |  |  | 0 |  |  |  | 24271185 | 2026.08 | ELOUADRHIRI L | 1 | 1 | H | LATIFA E | 4211 | Phil | 12-024 | 13-002F | EJ | 13-015 | PR |  |  |  |  |  |  |
| 242751345 |  | Torus - Main Cold mass support system - Supports Analyses | 20d | 2013-09-03 A | 2013-09-23 A | 9-130M FS+228d | 100% |  | 2013-10-01 | 2013-10-28 |  |  | 8/5 M-F w/JLAB Holidays ReBaseline | MECH ENG [16 h] | 1,194.72 | 1,157.76 |  |  |  |  | 0 |  |  |  | 24271240 | 1157.76 | ELOUADRHIRI L | 1 | 1 | H | LATIFA E | 4211 | Phil | 12-024 | 13-002F | EJ | 13-015 | PR |  |  |  |  |  |  |
| 242751350 |  | Torus - Main Cold mass support system - Supports Modeling FY13 | 20d | 2013-09-03 A | 2013-12-02 | 242751345 FS-20d | 50% | 20d | 2013-10-01 | 2013-10-28 | 137d | 20d | 8/5 M-F w/JLAB Holidays ReBaseline | MECH DES [8 h] | 410.4 | 198.84 |  |  |  |  | 0 |  |  |  | 24271245 | 198.84 | ELOUADRHIRI L | 1 | 1 | H | LATIFA E | 4211 | Phil | 12-024 | 13-002F | EJ | 13-015 | PR |  |  |  |  |  |  |
| 242751350a |  | Torus - Main Cold mass support system - Supports Modeling FY14 | 20d | 2013-09-03 A | 2013-12-02 |  | 50% | 20d | 2013-10-01 | 2013-10-28 | 137d | 20d | 8/5 M-F w/JLAB Holidays ReBaseline | MECH DES [8 h] | 410.4 | 198.84 |  |  |  |  | 0 |  |  |  | 24271245 | 205.2 | ELOUADRHIRI L | 1 | 1 | H | LATIFA E | 4211 | Phil | 12-024 | 13-002F | EJ | 13-015 | PR |  |  | 14-001 |  |  |  |
| 242751355 |  | Torus - Main Cold mass support system - Supports Drafting FY13 | 20d | 2013-09-03 A | 2013-12-02 | 242751350a FS-40d, 242751350 FS-40d | 50% | 20d | 2013-10-01 | 2013-10-28 | 117d | 0d | 8/5 M-F w/JLAB Holidays ReBaseline | MECH DES [16 h] | 820.8 | 397.68 |  |  |  |  | 0 |  |  |  | 24271250 | 397.68 | ELOUADRHIRI L | 1 | 1 | H | LATIFA E | 4211 | Phil | 12-024 | 13-002F | EJ | 13-015 | PR |  |  |  |  |  |  |
| 242751355a |  | Torus - Main Cold mass support system - Supports Drafting FY14 | 20d | 2013-09-03 A | 2013-12-02 | 242751355 FS-20d, 242751350a FS-40d | 50% | 20d | 2013-10-29 | 2013-11-25 | 117d | 20d | 8/5 M-F w/JLAB Holidays ReBaseline | MECH DES [16 h] | 820.8 | 397.68 |  |  |  |  | 0 |  |  |  | 24271250 | 410.4 | ELOUADRHIRI L | 1 | 1 | H | LATIFA E | 4211 | Phil | 12-024 | 13-002F | EJ | 13-015 | PR |  |  | 14-001 |  |  |  |
| 242751425 |  | Torus - LOV analyses - 4K piping analysis FY13 | 20d | 2013-09-03 A | 2013-12-13 | 9-130M FS+228d | 50% | 29d | 2013-10-01 | 2013-10-28 | 523d | 1d | 8/5 M-F w/JLAB Holidays ReBaseline | MECH ENG [16.33 h] | 1,219.36 | 482.3 |  |  |  |  | 0 |  |  |  | 24271268 | 590.8194 | ELOUADRHIRI L | 1 | 1 | H | LATIFA E | 4211 | Phil | 12-024 | 13-002F | EJ | 13-015 | PR |  |  |  |  |  |  |
| 242751425a |  | Torus - LOV analyses - 4K piping analysis FY14 | 29d | 2013-09-03 A | 2013-12-13 | 242751425 FS-30d | 50% | 29d | 2013-10-29 | 2013-12-10 | 523d | 15d | 8/5 M-F w/JLAB Holidays ReBaseline | MECH ENG [23.67 h] | 1,767.44 | 699.09 |  |  |  |  | 0 |  |  |  | 24271268 | 883.71945 | ELOUADRHIRI L | 1 | 1 | H | LATIFA E | 4211 | Phil | 12-024 | 13-002F | EJ | 13-015 | PR |  |  | 14-001 |  |  |  |
| 242751430 |  | Torus - LOV analyses - LN2 Piping FY13 | 15d | 2013-09-03 A | 2013-12-16 | 242751425 FS-44d, 242751425a FS-44d | 50% | 30d | 2013-10-01 | 2013-10-21 | 508d | 0d | 8/5 M-F w/JLAB Holidays ReBaseline | MECH ENG [13.33 h] | 995.35 | 385.82 |  |  |  |  | 0 |  |  |  | 24271270 | 482.2794 | ELOUADRHIRI L | 1 | 1 | H | LATIFA E | 4211 | Phil | 12-024 | 13-002F | EJ | 13-015 | PR |  |  |  |  |  |  |
| 242751430a |  | Torus - LOV analyses - LN2 Piping FY14 | 30d | 2013-09-03 A | 2013-12-16 | 242751425a FS-44d, 242751430 FS-30d | 50% | 30d | 2013-10-22 | 2013-12-04 | 508d | 10d | 8/5 M-F w/JLAB Holidays ReBaseline | MECH ENG [26.67 h] | 1,991.45 | 771.94 |  |  |  |  | 0 |  |  |  | 24271270 | 995.72445 | ELOUADRHIRI L | 1 | 1 | H | LATIFA E | 4211 | Phil | 12-024 | 13-002F | EJ | 13-015 | PR |  |  | 14-001 |  |  |  |
| 242751435 |  | Torus - LOV analyses - Service module FY13 | 10d | 2013-09-03 A | 2013-12-16 | 242751430 FS-40d, 242751430a FS-40d | 50% | 30d | 2013-10-08 | 2013-10-21 | 498d | 0d | 8/5 M-F w/JLAB Holidays ReBaseline | MECH ENG [10 h] | 746.7 | 289.44 |  |  |  |  | 0 |  |  |  | 24271275 | 361.8 | ELOUADRHIRI L | 1 | 1 | H | LATIFA E | 4211 | Phil | 12-024 | 13-002F | EJ | 13-015 | PR |  |  |  |  |  |  |
| 242751435a |  | Torus - LOV analyses - Service module FY14 | 30d | 2013-09-03 A | 2013-12-16 | 242751435 FS-30d, 242751430a FS-40d | 50% | 30d | 2013-10-22 | 2013-12-04 | 498d | 591d | 8/5 M-F w/JLAB Holidays ReBaseline | MECH ENG [30 h] | 2,240.1 | 868.32 |  |  |  |  | 0 |  |  |  | 24271275 | 1120.05 | ELOUADRHIRI L | 1 | 1 | H | LATIFA E | 4211 | Phil | 12-024 | 13-002F | EJ | 13-015 | PR |  |  | 14-001 |  |  |  |
| 242751445 |  | Torus - Engineering Procured Labor Phase 1 | 20d | 2013-09-03 A | 2013-12-02 | 9-130M FS+228d | 10% | 20d | 2013-10-01 | 2013-10-28 | 367d | 0d | 8/5 M-F w/JLAB Holidays ReBaseline | PROCUREMENT<$50K 60 | 35,259.3 |  | 31733.37 | 3525.93 | 352593 | 100 | 0 |  |  |  | 24271370 | 3525.93 | ELOUADRHIRI L | 1 | 1 | D | LATIFA E | 4211 |  | 12-024 | 13-002F |  | 13-015 | PR | OB-2 | OB |  |  |  |  |
| 242751150 |  | Torus - Cold Hub - Magnet construction analysis | 43d | 2013-09-09 A | 2013-12-16 | 9-140M |  | 30d | 2013-10-15 | 2013-12-16 | 81d | 11d | 8/5 M-F w/JLAB Holidays ReBaseline | MECH ENG [33.6 h] | 2,508.91 | 1,400.08 |  |  |  |  | 0 |  |  |  | 24271130 |  | ELOUADRHIRI L | 1 | 1 | S | LATIFA E | 4211 | Phil | 12-024 | 13-002F | EJ | 13-015 | PR |  |  | 14-001 | ST |  |  |
| 242751360 |  | Torus - Main Cold mass support system - Attachment to Floor Engineering | 15d | 2013-09-16 A | 2013-11-21 | 242751355 FS-40d, 242751355a FS-40d | 50% | 15d | 2014-01-22 | 2014-02-11 | 97d | 5d | 8/5 M-F w/JLAB Holidays ReBaseline | MECH ENG [120 h] | 8,960.4 | 3,673.66 |  |  |  |  | 0 |  |  |  | 24271255 | 4480.2 | ELOUADRHIRI L | 1 | 1 | H | LATIFA E | 4211 | Phil | 12-024 | 13-002F | EJ | 13-015 | PR |  |  | 14-001 |  |  |  |
| 242751365 |  | Torus - Main Cold mass support system - Attachment to Floor Modeling and Drafting | 14d | 2013-09-16 A | 2013-11-20 | 242751360 FS-20d | 50% | 14d | 2014-02-12 | 2014-03-03 | 92d | 0d | 8/5 M-F w/JLAB Holidays ReBaseline | MECH ENG [120 h] | 8,960.4 | 3,820.61 |  |  |  |  | 0 |  |  |  | 24271260 | 4480.2 | ELOUADRHIRI L | 1 | 1 | H | LATIFA E | 4211 | Phil | 12-024 | 13-002F | EJ | 13-015 | PR |  |  | 14-001 |  |  |  |
| 242751390 |  | Torus - Installation Design - Develop Installation Tooling Design | 41d | 2013-09-16 A | 2014-01-10 | 242751365 FS-22d |  | 41d | 2013-10-01 | 2013-11-26 | 84d | 0d | 8/5 M-F w/JLAB Holidays ReBaseline | MECH ENG [160 h] | 11,947.2 | 2,449.11 |  |  |  |  | 0 |  |  |  | 24271280 |  | ELOUADRHIRI L | 1 | 1 | S | LATIFA E | 4211 | Phil | 12-024 | 13-002F | EJ | 13-015 | PR |  |  | 14-001 | ST |  |  |
| 242751395 |  | Torus - Installation Design - Model Installation Tooling | 20d | 2013-09-16 A | 2013-12-02 | 242751390 FS-45d |  | 20d | 2013-10-30 | 2013-11-26 | 80d | 0d | 8/5 M-F w/JLAB Holidays ReBaseline | MECH ENG [160 h] | 11,947.2 | 4,108.18 |  |  |  |  | 0 |  |  |  | 24271285 |  | ELOUADRHIRI L | 1 | 1 | S | LATIFA E | 4211 | Phil | 12-024 | 13-002F | EJ | 13-015 | PR |  |  | 14-001 | ST |  |  |
| 242751400 |  | Torus - Installation Design - Analyze Installation Tooling | 30d | 2013-09-16 A | 2013-12-16 | 242751395 FS-20d | 50% | 30d | 2013-10-02 | 2013-11-12 | 80d | 0d | 8/5 M-F w/JLAB Holidays ReBaseline | MECH ENG [80 h] | 5,973.6 | 1,553.09 |  |  |  |  | 0 |  |  |  | 24271290 | 2986.8 | ELOUADRHIRI L | 1 | 1 | H | LATIFA E | 4211 | Phil | 12-024 | 13-002F | EJ | 13-015 | PR |  |  | 14-001 |  |  |  |
| 242751005LOE |  | Torus - Engineering Oversight FY14 | 247d | 2013-10-01 A | 2014-09-30 | 242751000LOE | 9% | 224d | 2013-11-01 | 2014-10-31 | 420d | 0d | 8/5 M-F w/JLAB Holidays ReBaseline | SR STAFF [2360 h] | 283,955.2 | 26,441.17 |  |  |  |  | 26436.22912 |  | 100 | 100 | 24271005LOE |  | ELOUADRHIRI L | 1 | 1 | E | LATIFA E | 4211 | Phil | 12-024 | 13-002F | EJ | 13-015 | PR |  |  | 14-001 |  | 90.6882591 | 9.31174089 |
| 242751090 |  | Torus - Vacuum Vessel Assembly Parts Procurement | 139d | 2013-10-21 A | 2014-04-08 | 242751080 FS-40d |  | 102d | 2013-11-19 | 2014-06-17 | 59d | 0d | 8/5 M-F w/JLAB Holidays ReBaseline | PROCUREMENT<$50K 60; PROCUREMENT>$50K 69 | 257,975 |  | 257975 | 0 | 0 | 100 | 0 |  |  |  | 24271094 |  | ELOUADRHIRI L | 1 | 1 | D | LATIFA E | 4211 | Phil | 12-024 | 13-002F |  | 13-015 | PR | OB-2 | EV | 14-001 |  |  |  |
| 242751115 |  | Torus - Coil Case Shields Procurement | 95d | 2013-10-21 A | 2014-02-03 | 242751110, 242751110a |  | 56d | 2013-12-09 | 2014-05-01 | 154d | 29d | 8/5 M-F w/JLAB Holidays ReBaseline | PROCUREMENT<$50K 60; PROCUREMENT>$50K 69 | 149,223.06 |  | 149223.06 | 0 | 0 | 100 | 0 |  |  |  | 24271114 |  | ELOUADRHIRI L | 1 | 1 | D | LATIFA E | 4211 | Phil | 12-024 | 13-002F |  | 13-015 | PR | OB-2 | EV | 14-001 |  |  |  |
| 242751145 |  | Torus - Out Of Plane Supports - OOPS Procurement | 87d | 2013-10-21 A | 2014-02-14 | 9-140M FS+11d |  | 65d | 2013-11-01 | 2014-03-18 | 128d | 10d | 8/5 M-F w/JLAB Holidays ReBaseline | PROCUREMENT<$50K 60; PROCUREMENT>$50K 69 | 144,466 |  | 144466 | 0 | 0 | 100 | 0 |  |  |  | 24271129 |  | ELOUADRHIRI L | 1 | 1 | D | LATIFA E | 4211 | Phil | 12-024 | 13-002F |  | 13-015 | PR | OB-2 | EV | 14-001 |  |  |  |
| 242751265 |  | Torus - Downstream Hex - 4K beam Stress Analysis | 10d | 2013-11-01 | 2013-11-14 | 242751215 FS-25d, 242751215a FS-25d |  |  |  |  | 25d | 0d | 8/5 M-F w/JLAB Holidays ReBaseline | MECH ENG [80 h] | 5,973.6 |  |  |  |  |  | 0 |  |  |  | 24271203 |  | ELOUADRHIRI L | 1 | 1 | H | LATIFA E | 4211 | Phil | 12-024 | 13-002F | EJ | 13-015 | PR |  |  | 14-001 |  |  |  |
| 242751125 |  | Torus - Coil Case MLI Procurement | 64d | 2013-11-18 | 2014-02-28 | 242751120a, 242751120 |  |  |  |  | 101d | 0d | 8/5 M-F w/JLAB Holidays ReBaseline | PROCUREMENT<$50K 60 | 21,669.9 |  | 21669.9 | 0 | 0 | 100 | 0 |  |  |  | 24271117 |  | ELOUADRHIRI L | 1 | 1 | D | LATIFA E | 4211 | Phil | 12-024 | 13-002F |  | 13-015 | PR |  | PE | 14-001 |  |  |  |
| 242751210 |  | Torus - Upstream Hex - Recooler Drafting | 18d | 2013-11-18 | 2013-12-13 | 242751205a, 242751200, 242751200a, 242751205 |  |  |  |  | 95d | 0d | 8/5 M-F w/JLAB Holidays ReBaseline | MECH DES [36 h] | 1,846.8 |  |  |  |  |  | 0 |  |  |  | 24271177 |  | ELOUADRHIRI L | 1 | 1 | H | LATIFA E | 4211 | Phil | 12-024 | 13-002F | EJ | 13-015 | PR |  |  | 14-001 |  |  |  |
| 242751370 |  | Torus - CM Support Assembly Parts Procurement Prep | 29d | 2013-11-21 | 2014-01-14 | 242751365 |  |  |  |  | 130d | 0d | 8/5 M-F w/JLAB Holidays ReBaseline | MECH ENG [40 h] | 2,986.8 |  |  |  |  |  | 0 |  |  |  | 24271262 |  | ELOUADRHIRI L | 1 | 1 | H | LATIFA E | 4211 | Phil | 12-024 | 13-002F | EJ | 13-015 | PR |  |  | 14-001 |  |  |  |
| 242751380 |  | Torus - Torus Support to Hall floor Assembly Procurement Prep | 23d | 2013-11-25 | 2014-01-08 | 242751365 FS+2d |  |  |  |  | 131d | 0d | 8/5 M-F w/JLAB Holidays ReBaseline | MECH ENG [40 h] | 2,986.8 |  |  |  |  |  | 0 |  |  |  | 24271265 |  | ELOUADRHIRI L | 1 | 1 | H | LATIFA E | 4211 | Phil | 12-024 | 13-002F | EJ | 13-015 | PR |  |  | 14-001 |  |  |  |
| 242751170 |  | Torus - Cold Hub - Hub shield final drafting | 22d | 2013-12-02 | 2014-01-10 | 242751165a, 242751165 |  |  |  |  | 70d | 0d | 8/5 M-F w/JLAB Holidays ReBaseline | MECH ENG [40 h] | 2,986.8 |  |  |  |  |  | 0 |  |  |  | 24271150 |  | ELOUADRHIRI L | 1 | 1 | H | LATIFA E | 4211 | Phil | 12-024 | 13-002F | EJ | 13-015 | PR |  |  | 14-001 |  |  |  |
| 242751275 |  | Torus - Downstream Hex - Shield final design and Drafting | 25d | 2013-12-02 | 2014-01-15 | 242751270 FS-6d |  |  |  |  | 25d | 0d | 8/5 M-F w/JLAB Holidays ReBaseline | MECH DES [136 h] | 6,976.8 |  |  |  |  |  | 0 |  |  |  | 24271210 |  | ELOUADRHIRI L | 1 | 1 | H | LATIFA E | 4211 | Phil | 12-024 | 13-002F | EJ | 13-015 | PR |  |  | 14-001 |  |  |  |
| 242751225 |  | Torus - Upstream Hex - Shield final design and Drafting | 18d | 2013-12-03 | 2014-01-07 | 242751220 FS+25d |  |  |  |  | 25d | 0d | 8/5 M-F w/JLAB Holidays ReBaseline | MECH DES [108.8 h] | 5,581.44 |  |  |  |  |  | 0 |  |  |  | 24271190 |  | ELOUADRHIRI L | 1 | 1 | S | LATIFA E | 4211 | Phil | 12-024 | 13-002F | EJ | 13-015 | PR |  |  | 14-001 |  |  |  |
| 242751230 |  | Torus - Upstream Hex - VJ final design and Drafting | 43d | 2013-12-03 | 2014-02-12 | 242751225 FS-18d |  |  |  |  | 25d | 0d | 8/5 M-F w/JLAB Holidays ReBaseline | MECH DES [40 h]; MECH ENG [40 h] | 5,038.8 |  |  |  |  |  | 0 |  |  |  | 24271195 |  | ELOUADRHIRI L | 1 | 1 | H | LATIFA E | 4211 | Phil | 12-024 | 13-002F | EJ | 13-015 | PR |  |  | 14-001 |  |  |  |
| 242751270 |  | Torus - Downstream Hex - 4K piping analysis | 5d | 2013-12-03 | 2013-12-09 | 242751265 FS+10d |  |  |  |  | 25d | 0d | 8/5 M-F w/JLAB Holidays ReBaseline | MECH ENG [40 h] | 2,986.8 |  |  |  |  |  | 0 |  |  |  | 24271205 |  | ELOUADRHIRI L | 1 | 1 | H | LATIFA E | 4211 | Phil | 12-024 | 13-002F | EJ | 13-015 | PR |  |  | 14-001 |  |  |  |
| 242751450 |  | Torus - Engineering Procured Labor Phase 2 | 141d | 2013-12-03 | 2014-07-01 | 242751445 |  |  |  |  | 367d | 460d | 8/5 M-F w/JLAB Holidays ReBaseline | PLABOR |  |  |  |  |  |  | 0 |  |  |  | 24271375 |  | ELOUADRHIRI L | 1 | 1 | D | LATIFA E | 4211 |  | 12-024 | 13-002F | EJ | 13-015 | PR |  |  |  |  |  |  |
| 242751245 |  | Torus - Recooler Procurement Prep | 23d | 2013-12-16 | 2014-01-28 | 242751210 |  |  |  |  | 95d | 0d | 8/5 M-F w/JLAB Holidays ReBaseline | MECH ENG [40 h] | 2,986.8 |  |  |  |  |  | 0 |  |  |  | 24271199 |  | ELOUADRHIRI L | 1 | 1 | H | LATIFA E | 4211 | Phil | 12-024 | 13-002F | EJ | 13-015 | PR |  |  | 14-001 |  |  |  |
| 242751280 |  | Torus - Downstream Hex - VJ final design and Drafting | 13d | 2013-12-17 | 2014-01-14 | 242751275 FS-14d |  |  |  |  | 25d | 0d | 8/5 M-F w/JLAB Holidays ReBaseline | MECH DES [40 h]; MECH ENG [40 h] | 5,038.8 |  |  |  |  |  | 0 |  |  |  | 24271215 |  | ELOUADRHIRI L | 1 | 1 | H | LATIFA E | 4211 | Phil | 12-024 | 13-002F | EJ | 13-015 | PR |  |  | 14-001 |  |  |  |
| 242751405 |  | Torus - Installation Design - Installation Tooling Drafting | 15d | 2013-12-17 | 2014-01-16 | 242751400 |  |  |  |  | 80d | 0d | 8/5 M-F w/JLAB Holidays ReBaseline | MECH DES [120 h] | 6,156 |  |  |  |  |  | 0 |  |  |  | 24271295 |  | ELOUADRHIRI L | 1 | 1 | H | LATIFA E | 4211 | Phil | 12-024 | 13-002F | EJ | 13-015 | PR |  |  | 14-001 |  |  |  |
| 242751235 |  | Torus - Upstream Hex Assembly Parts Procurement Prep | 29d | 2014-01-08 | 2014-02-18 | 242751230 FS-25d |  |  |  |  | 25d | 0d | 8/5 M-F w/JLAB Holidays ReBaseline | MECH ENG [40 h] | 2,986.8 |  |  |  |  |  | 0 |  |  |  | 24271197 |  | ELOUADRHIRI L | 1 | 1 | H | LATIFA E | 4211 | Phil | 12-024 | 13-002F | EJ | 13-015 | PR |  |  | 14-001 |  |  |  |
| 242751385 |  | Torus - Torus Support to Hall floor Assembly Procurement | 58d | 2014-01-09 | 2014-04-01 | 242751380 |  |  |  |  | 131d | 77d | 8/5 M-F w/JLAB Holidays ReBaseline | PROCUREMENT<$50K 60; PROCUREMENT>$50K 69 | 77,392.5 |  | 77392.5 | 0 | 0 | 100 | 0 |  |  |  | 24271266 |  | ELOUADRHIRI L | 1 | 1 | D | LATIFA E | 4211 | Phil | 12-024 | 13-002F |  | 13-015 | PR |  | EV | 14-001 |  |  |  |
| 242751175 |  | Torus - Cold Hub Procurement Prep | 34d | 2014-01-13 | 2014-02-28 | 242751170, 242751150 |  |  |  |  | 70d | 0d | 8/5 M-F w/JLAB Holidays ReBaseline | MECH ENG [40 h] | 2,986.8 |  |  |  |  |  | 0 |  |  |  | 24271152 |  | ELOUADRHIRI L | 1 | 1 | H | LATIFA E | 4211 | Phil | 12-024 | 13-002F | EJ | 13-015 | PR |  |  | 14-001 |  |  |  |
| 242751415 |  | Torus - Installation Design - Develop procedures and safety documentation | 26d | 2014-01-13 | 2014-02-18 | 242751390 |  |  |  |  | 142d | 117d | 8/5 M-F w/JLAB Holidays ReBaseline | MECH ENG [372 h] | 27,777.24 |  |  |  |  |  | 0 |  |  |  | 24271305 |  | ELOUADRHIRI L | 1 | 1 | S | LATIFA E | 4211 | Phil | 12-024 | 13-002F | EJ | 13-015 | PR |  |  | 14-001 |  |  |  |
| 242751285 |  | Torus - Downstream Hex Assembly Parts Procurement Prep | 19d | 2014-01-15 | 2014-02-11 | 242751280 |  |  |  |  | 25d | 0d | 8/5 M-F w/JLAB Holidays ReBaseline | MECH ENG [40 h] | 2,986.8 |  |  |  |  |  | 0 |  |  |  | 24271217 |  | ELOUADRHIRI L | 1 | 1 | H | LATIFA E | 4211 | Phil | 12-024 | 13-002F | EJ | 13-015 | PR |  |  | 14-001 |  |  |  |

Notes:
- 242751150: Steps: Determination of Installation Stages; FEA
- 242751390: Steps: Concept for Installation Method; Initial Sizing for Structure; Model Support Structure Concept; FEA
- 242751395: Steps: Locate Pillow Blocks for support; Model Upstream Support Structure; Model Downstream Support Structure

| ID | WBS | Activity | Duration | Start | Finish | Predecessors | Complete | Remaining | Planned start | Planned finish | Total float | Free float | Calendar | Resources | Cost | Actual cost | Original Activity ID Rebaseline | Remaining Material Cost Based on % Compl | Claimed Material Cost Based on % Complet | Initial Claimed Material Calc | Claimed Material Divider | MONTHLY EV COST | RESP - Responsibility | STRT%COMP for CM EVM | FNSH%COMP for CM EVM | EVMS Reporting Codes | CAM RESPONSIBLE | 12 GEV MAJOR PROCUREMENT CATAGORY | Phil Dev | CR 12-024 | CR 13-002 | BOE Procurement | CR 13-015 | Post Rebaseline | CR 14-001 | BOE Labor | LOE % Pre Calc | LOE % | LOE Divider | LOE Multiplier | ReBaseline Actuals Adjustment | PRIOR MONTH EV COST |
| --- | --- | --- | --- | --- | --- | --- | --- | --- | --- | --- | --- | --- | --- | --- | --- | --- | --- | --- | --- | --- | --- | --- | --- | --- | --- | --- | --- | --- | --- | --- | --- | --- | --- | --- | --- | --- | --- | --- | --- | --- | --- | --- |
| 242751375 |  | Torus - CM Support Assembly Parts Procurement | 75d | 2014-01-15 | 2014-04-30 | 242751370 |  |  |  |  | 130d | 60d | 8/5 M-F w/JLAB Holidays ReBaseline | PROCUREMENT<$50K 60; PROCUREMENT>$50K 69 | 68,105.4 |  | 24271264 | 68105.4 | 0 | 0 | 100 | 0 | ELOUADRHIRI L | 1 | 1 | D | LATIFA E | 4211 | Phil | 12-024 | 13-002F | EV | 13-015 | PR | 14-001 |  |  |  |  |  |  |  |
| 242751410 |  | Torus - Installation Design - Develop Scaffolding Design | 10d | 2014-01-17 | 2014-01-31 | 242751405 |  |  |  |  | 100d | 20d | 8/5 M-F w/JLAB Holidays ReBaseline | MECH DES [80 h] | 4,104 |  | 24271300 |  |  |  |  | 0 | ELOUADRHIRI L | 1 | 1 | H | LATIFA E | 4211 | Phil | 12-024 | 13-002F |  | 13-015 | PR | 14-001 | EJ |  |  |  |  |  |  |
| 242751420 |  | Torus - Installation Parts Procurement Prep | 26d | 2014-01-17 | 2014-02-24 | 242751405, 242751410 FS-30d |  |  |  |  | 80d | 0d | 8/5 M-F w/JLAB Holidays ReBaseline | MECH ENG [40 h] | 2,986.8 |  | 24271310 |  |  |  |  | 0 | ELOUADRHIRI L | 1 | 1 | H | LATIFA E | 4211 | Phil | 12-024 | 13-002F |  | 13-015 | PR | 14-001 | EJ |  |  |  |  |  |  |
| 242751250 |  | Torus - Recooler Procurement | 62d | 2014-01-29 | 2014-04-24 | 242751245 |  |  |  |  | 95d | 70d | 8/5 M-F w/JLAB Holidays ReBaseline | PROCUREMENT<$50K 60; PROCUREMENT>$50K 69 | 66,400.7 |  | 24271200 | 66400.7 | 0 | 0 | 100 | 0 | ELOUADRHIRI L | 1 | 1 | D | LATIFA E | 4211 | Phil | 12-024 | 13-002F | EV | 13-015 | PR | 14-001 |  |  |  |  |  |  |  |
| 242751315 |  | Torus - Supply-Return Header to DS ring - Modeling | 25d | 2014-02-07 | 2014-03-13 | 242751280 FF+16d, 242751280 FS+16d |  |  |  |  | 131d | 0d | 8/5 M-F w/JLAB Holidays ReBaseline | MECH ENG [40 h] | 2,986.8 |  | 24271226 |  |  |  |  | 0 | ELOUADRHIRI L | 1 | 1 | H | LATIFA E | 4211 | Phil | 12-024 | 13-002F |  | 13-015 | PR | 14-001 | EJ |  |  |  |  |  |  |
| 242751320 |  | Torus - Supply-Return Header to DS ring - Piping flexibility analysis | 25d | 2014-02-07 | 2014-03-13 | 242751315 FS-25d |  |  |  |  | 131d | 0d | 8/5 M-F w/JLAB Holidays ReBaseline | MECH ENG [40 h] | 2,986.8 |  | 24271227 |  |  |  |  | 0 | ELOUADRHIRI L | 1 | 1 | H | LATIFA E | 4211 | Phil | 12-024 | 13-002F |  | 13-015 | PR | 14-001 | EJ |  |  |  |  |  |  |
| 242751440 |  | Torus - Installation Parts Procurement (90K Accounted for Cryo Jumpers) | 77d | 2014-02-25 | 2014-06-12 | 242751420 |  |  |  |  | 80d | 26d | 8/5 M-F w/JLAB Holidays ReBaseline | PROCUREMENT<$50K 60; PROCUREMENT>$50K 69 | 185,742 |  | 24271315 | 185742 | 0 | 0 | 100 | 0 | ELOUADRHIRI L | 1 | 1 | D | LATIFA E | 4211 | Phil | 12-024 | 13-002F | EV | 13-015 | PR | 14-001 |  |  |  |  |  |  |  |
| 242751295 |  | Torus - Downstream Hex MLI Procurement Prep | 20d | 2014-02-28 | 2014-03-27 | 242751275 FS+30d |  |  |  |  | 170d | 0d | 8/5 M-F w/JLAB Holidays ReBaseline | MECH ENG [40 h] | 2,986.8 |  | 24271221 |  |  |  |  | 0 | ELOUADRHIRI L | 1 | 1 | H | LATIFA E | 4211 | Phil | 12-024 | 13-002F |  | 13-015 | PR | 14-001 | EJ |  |  |  |  |  |  |
| 242751305 |  | Torus - Misc Hex MLI Procurement Prep | 20d | 2014-02-28 | 2014-03-27 | 242751275 FS+30d |  |  |  |  | 170d | 0d | 8/5 M-F w/JLAB Holidays ReBaseline | MECH ENG [40 h] | 2,986.8 |  | 24271224 |  |  |  |  | 0 | ELOUADRHIRI L | 1 | 1 | H | LATIFA E | 4211 | Phil | 12-024 | 13-002F |  | 13-015 | PR | 14-001 | EJ |  |  |  |  |  |  |
| 242751180 |  | Torus - Cold Hub Procurement | 64d | 2014-03-03 | 2014-05-30 | 242751175 |  |  |  |  | 70d | 45d | 8/5 M-F w/JLAB Holidays ReBaseline | PROCUREMENT<$50K 60 | 19,791.84 |  | 24271154 | 19791.84 | 0 | 0 | 100 | 0 | ELOUADRHIRI L | 1 | 1 | D | LATIFA E | 4211 | Phil | 12-024 | 13-002F | EV | 13-015 | PR | 14-001 |  |  |  |  |  |  |  |
| 242751255 |  | Torus - Upstream Hex MLI Procurement Prep | 20d | 2014-03-07 | 2014-04-03 | 242751225 FS+41d |  |  |  |  | 165d | 0d | 8/5 M-F w/JLAB Holidays ReBaseline | MECH ENG [40 h] | 2,986.8 |  | 24271201 |  |  |  |  | 0 | ELOUADRHIRI L | 1 | 1 | H | LATIFA E | 4211 | Phil | 12-024 | 13-002F |  | 13-015 | PR | 14-001 | EJ |  |  |  |  |  |  |
| 242751240 |  | Torus - Upstream Hex Assembly Parts Procurement | 102d | 2014-03-12 | 2014-08-04 | 242751235 FS+15d |  |  |  |  | 25d | 0d | 8/5 M-F w/JLAB Holidays ReBaseline | PROCUREMENT<$50K 60; PROCUREMENT>$50K 69 | 101,618.42 |  | 24271198 | 101618.42 | 0 | 0 | 100 | 0 | ELOUADRHIRI L | 1 | 1 | D | LATIFA E | 4211 | Phil | 12-024 | 13-002F | EV | 13-015 | PR | 14-001 |  |  |  |  |  |  |  |
| 242751290 |  | Torus - Downstream Hex Assembly Parts Procurement | 102d | 2014-03-12 | 2014-08-04 | 242751285 FS+20d |  |  |  |  | 25d | 0d | 8/5 M-F w/JLAB Holidays ReBaseline | PROCUREMENT<$50K 60; PROCUREMENT>$50K 69 | 74,429.92 |  | 24271219 | 74429.92 | 0 | 0 | 100 | 0 | ELOUADRHIRI L | 1 | 1 | D | LATIFA E | 4211 | Phil | 12-024 | 13-002F | EV | 13-015 | PR | 14-001 |  |  |  |  |  |  |  |
| 242751325 |  | Torus - Supply-Return Header to DS ring - Modeling/Drafting | 15d | 2014-03-14 | 2014-04-03 | 242751320 |  |  |  |  | 131d | 0d | 8/5 M-F w/JLAB Holidays ReBaseline | MECH DES [80 h] | 4,104 |  | 24271230 |  |  |  |  | 0 | ELOUADRHIRI L | 1 | 1 | H | LATIFA E | 4211 | Phil | 12-024 | 13-002F |  | 13-015 | PR | 14-001 | EJ |  |  |  |  |  |  |
| 242751300 |  | Torus - Downstream Hex MLI Procurement | 60d | 2014-03-27 | 2014-06-19 | 242751295 FS-1d |  |  |  |  | 170d | 145d | 8/5 M-F w/JLAB Holidays ReBaseline | PROCUREMENT<$50K 60 | 6,191.4 |  | 24271222 | 6191.4 | 0 | 0 | 100 | 0 | ELOUADRHIRI L | 1 | 1 | D | LATIFA E | 4211 | Phil | 12-024 | 13-002F | EV | 13-015 | PR | 14-001 |  |  |  |  |  |  |  |
| 242751310 |  | Torus - Misc Hex MLI Procurement | 59d | 2014-03-28 | 2014-06-19 | 242751305 |  |  |  |  | 170d | 145d | 8/5 M-F w/JLAB Holidays ReBaseline | PROCUREMENT<$50K 60 | 6,191.4 |  | 24271225 | 6191.4 | 0 | 0 | 100 | 0 | ELOUADRHIRI L | 1 | 1 | D | LATIFA E | 4211 | Phil | 12-024 | 13-002F | EV | 13-015 | PR | 14-001 |  |  |  |  |  |  |  |
| 242751260 |  | Torus - Upstream Hex MLI Procurement | 59d | 2014-04-04 | 2014-06-26 | 242751255 |  |  |  |  | 165d | 140d | 8/5 M-F w/JLAB Holidays ReBaseline | PROCUREMENT<$50K 60 | 6,191.4 |  | 24271202 | 6191.4 | 0 | 0 | 100 | 0 | ELOUADRHIRI L | 1 | 1 | D | LATIFA E | 4211 | Phil | 12-024 | 13-002F | EV | 13-015 | PR | 14-001 |  |  |  |  |  |  |  |
| 242751330 |  | Torus - Supply-Return Header Procurement Prep | 35d | 2014-04-04 | 2014-05-22 | 242751325 |  |  |  |  | 131d | 0d | 8/5 M-F w/JLAB Holidays ReBaseline | MECH ENG [40 h] | 2,986.8 |  | 24271232 |  |  |  |  | 0 | ELOUADRHIRI L | 1 | 1 | H | LATIFA E | 4211 | Phil | 12-024 | 13-002F |  | 13-015 | PR | 14-001 | EJ |  |  |  |  |  |  |
| 242751335 |  | Torus - Supply-Return Header Procurement | 40d | 2014-05-23 | 2014-07-21 | 242751330 |  |  |  |  | 131d | 106d | 8/5 M-F w/JLAB Holidays ReBaseline | PROCUREMENT<$50K 60 | 8,255.2 |  | 24271234 | 8255.2 | 0 | 0 | 100 | 0 | ELOUADRHIRI L | 1 | 1 | D | LATIFA E | 4211 | Phil | 12-024 | 13-002F | EV | 13-015 | PR | 14-001 |  |  |  |  |  |  |  |
| 242751010LOE |  | Torus - Engineering Oversight FY15 | 15d | 2014-10-01 | 2014-10-21 | 242751005LOE |  |  |  |  | 420d | 0d | 8/5 M-F w/JLAB Holidays ReBaseline | SR STAFF [190 h] | 22,860.8 |  | 24271010LOE |  |  |  |  | 0 | ELOUADRHIRI L | 1 | 1 | E | LATIFA E | 4211 | Phil | 12-024 | 13-002F |  | 13-015 | PR | 14-001 | EJ | 100 | 0 | 100 | 100 |  |  |
|  | 6 | **1.4.2.7.6 TORUS CRYOGENICS** |  | 2013-08-30 | 2015-03-30 |  |  |  |  |  |  |  |  |  |  |  |  |  |  |  |  |  |  |  |  |  |  |  |  |  |  |  |  |  |  |  |  |  |  |  |  |  |
|  | 1 | **1.4.2.7.6.1 CRYO DISTRIBUTION CAN** |  | 2013-08-30 | 2014-10-02 |  |  |  |  |  |  |  |  |  |  |  |  |  |  |  |  |  |  |  |  |  |  |  |  |  |  |  |  |  |  |  |  |  |  |  |  |  |
| 142761000 |  | Re-Baseline Actuals Adjustment | 1d | 2013-08-30 A | 2013-08-30 A |  | 100% |  | 2013-09-03 | 2013-09-03 |  |  |  | PROCUREMENT>$50K 69 NO ESCALATION | 22,530.01 |  |  | 0 | 22530.01 | 2253001 | 100 | 22530.01 |  |  |  |  |  |  |  |  |  |  |  |  |  |  |  |  |  |  | ADJ |  |
| 242761010 |  | Torus - Distribution Can - ProjectMgt FY13 | 13d | 2013-09-03 A | 2013-11-18 | 242761005 FS-20d | 50% | 12d | 2013-10-28 | 2013-11-13 | 130d | 0d | 8/5 M-F w/JLAB Holidays ReBaseline | MECH ENG [7.69 h] | 574.21 | 347.78 | 24271350 |  |  |  |  | 0 | ELOUADRHIRI L | 1 | 1 | H | LATIFA E | 4211 | Phil | 12-024 | 13-002F |  | 13-015 | PR |  | EJ |  |  |  |  |  | 278.2242 |
| 242761010a |  | Torus - Distribution Can - ProjectMgt FY14 | 12d | 2013-09-03 A | 2013-11-18 | 242761010 FS-40d | 50% | 12d | 2013-10-01 | 2013-10-16 | 130d | 0d | 8/5 M-F w/JLAB Holidays ReBaseline | MECH ENG [92.31 h] | 6,892.79 | 4,174.72 | 24271350 |  |  |  |  | 0 | ELOUADRHIRI L | 1 | 1 | H | LATIFA E | 4211 | Phil | 12-024 | 13-002F |  | 13-015 | PR | 14-001 | EJ |  |  |  |  |  | 3446.39385 |
| 242761020 |  | Torus - Distribution Can - Write Specs | 15d | 2013-09-16 A | 2014-01-09 | 242761015 FS-25d | 50% | 40d | 2013-11-06 | 2013-11-26 | 130d | 0d | 8/5 M-F w/JLAB Holidays ReBaseline | MECH ENG [120 h] | 8,960.4 | 1,872.85 | 24271350 |  |  |  |  | 0 | ELOUADRHIRI L | 1 | 1 | H | LATIFA E | 4211 | Phil | 12-024 | 13-002F |  | 13-015 | PR | 14-001 | EJ |  |  |  |  |  | 4480.2 |
| 242761000 |  | Torus - Distribution Can - Drafting Mechanical | 11d | 2013-11-01 | 2013-11-15 | 9-130M FS+228d |  |  |  |  | 131d | 0d | 8/5 M-F w/JLAB Holidays ReBaseline | MECH DES [88 h] | 4,514.4 |  | 24271350 |  |  |  |  | 0 | ELOUADRHIRI L | 1 | 1 | H | LATIFA E | 4211 | Phil | 12-024 | 13-002F |  | 13-015 | PR |  | EJ |  |  |  |  |  |  |
| 242761005 |  | Torus - Distribution Can - Drafting Structural | 8d | 2013-11-18 | 2013-11-27 | 242761000 |  |  |  |  | 131d | 1d | 8/5 M-F w/JLAB Holidays ReBaseline | MECH DES [64 h] | 3,283.2 |  | 24271350 |  |  |  |  | 0 | ELOUADRHIRI L | 1 | 1 | H | LATIFA E | 4211 | Phil | 12-024 | 13-002F |  | 13-015 | PR |  | EJ |  |  |  |  |  |  |
| 242761015 |  | Torus - Distribution Can - QA | 13d | 2013-11-19 | 2013-12-09 | 242761010a, 242761010 |  |  |  |  | 130d | 0d | 8/5 M-F w/JLAB Holidays ReBaseline | MECH ENG [104 h] | 7,765.68 |  | 24271350 |  |  |  |  | 0 | ELOUADRHIRI L | 1 | 1 | H | LATIFA E | 4211 | Phil | 12-024 | 13-002F |  | 13-015 | PR | 14-001 | EJ |  |  |  |  |  |  |
| 242761025 |  | Torus - Distribution Can - Bid and select vendor | 40d | 2014-01-10 | 2014-03-07 | 242761020 |  |  |  |  | 130d | 0d | 8/5 M-F w/JLAB Holidays ReBaseline | MECH ENG [80 h] | 5,973.6 |  | 24271350 |  |  |  |  | 0 | ELOUADRHIRI L | 1 | 1 | H | LATIFA E | 4211 | Phil | 12-024 | 13-002F |  | 13-015 | PR | 14-001 | EJ |  |  |  |  |  |  |
| 242761030 |  | Torus - Cryogenic Distribution Can Procurement | 128d | 2014-04-03 | 2014-10-02 | 242761025 FS+18d |  |  |  |  | 130d | 0d | 8/5 M-F w/JLAB Holidays ReBaseline | PROCUREMENT<$50K 60; PROCUREMENT>$50K 69 | 372,976.13 |  | 24271355 | 372976.13 | 0 | 0 | 100 | 0 | ELOUADRHIRI L | 1 | 1 | D | LATIFA E | 4211 | Phil | 12-024 | 13-002F | PE | 13-015 | PR | 14-001 |  |  |  |  |  |  |  |

| ID | WBS | Activity | Duration | Start | Finish | Predecessors | Complete | Remaining | Planned start | Planned finish | Total float | Free float | Calendar | Resources | Cost | Actual cost | Remaining Material Cost Based on % Compl | Claimed Material Cost Based on % Complet | Initial Claimed Material Calc | Claimed Material Divider | MONTHLY EV COST | ReBaseline Actuals Adjustment | Original Activity ID Rebaseline | RESP - Responsibility | STRT%COMP for CM EVM | FNSH%COMP for CM EVM | EVMS Reporting Codes | CAM RESPONSIBLE | 12 GEV MAJOR PROCUREMENT CATAGORY | Phil Dev | CR 12-024 | CR 13-002 | BOE Labor | CR 13-015 | Post Rebaseline | CR 14-001 | PRIOR MONTH EV COST | BOE Procurement |
| --- | --- | --- | --- | --- | --- | --- | --- | --- | --- | --- | --- | --- | --- | --- | --- | --- | --- | --- | --- | --- | --- | --- | --- | --- | --- | --- | --- | --- | --- | --- | --- | --- | --- | --- | --- | --- | --- | --- |
|  | 2 | **1.4.2.7.6.2 CRYO CONTROL CAN** |  | 2013-08-30 | 2015-03-30 |  |  |  |  |  |  |  |  |  |  |  |  |  |  |  |  |  |  |  |  |  |  |  |  |  |  |  |  |  |  |  |  |  |
| 142762000 |  | Re-Baseline Actuals Adjustment | 1d | 2013-08-30 A | 2013-08-30 A |  | 100% |  | 2013-09-03 | 2013-09-03 |  |  |  | PROCUREMENT>$50K 69 NO ESCALATION | 4,010.76 |  | 0 | 4010.76 | 401076 | 100 | 4010.76 | ADJ |  |  |  |  |  |  |  |  |  |  |  |  |  |  |  |  |
| 242762000 |  | Torus - Cryogenic Tower - Mechanical Engineering FY13 | 20d | 2013-09-03 A | 2013-12-18 | 9-130M FS+228d |  | 32d | 2013-10-01 | 2013-10-28 | 105d | 8d | 8/5 M-F w/JLAB Holidays ReBaseline | MECH ENG [160 h] | 11,947.2 | 6,751.17 |  |  |  |  | 0 |  | 24271360 | ELOUADRHIRI L | 1 | 1 | S | LATIFA E | 4211 | Phil | 12-024 | 13-002F | EJ | 13-015 | PR |  |  |  |
| 242762000a |  | Torus - Cryogenic Tower - Mechanical Engineering FY14 | 55d | 2013-09-03 A | 2013-12-18 | 242762000 FS-60d |  | 32d | 2013-10-01 | 2013-12-18 | 105d | 8d | 8/5 M-F w/JLAB Holidays ReBaseline | MECH ENG [440 h] | 32,854.8 | 18,565.71 |  |  |  |  | 0 |  | 24271360 | ELOUADRHIRI L | 1 | 1 | S | LATIFA E | 4211 | Phil | 12-024 | 13-002F | EJ | 13-015 | PR | 14-001 |  |  |
| 242762010 |  | Torus - Cryogenic Tower - Electrical/Instrumentation Engineering | 5d | 2013-09-16 A | 2014-01-21 | 242762005 FS-70d | 50% | 47d | 2014-02-12 | 2014-02-18 | 69d | 28d | 8/5 M-F w/JLAB Holidays ReBaseline | ELEC ENG [40 h] | 3,005.2 | 1,248.84 |  |  |  |  | 0 |  | 24271360 | ELOUADRHIRI L | 1 | 1 | H | LATIFA E | 4211 | Phil | 12-024 | 13-002F | EJ | 13-015 | PR | 14-001 | 1502.6 |  |
| 242762015 |  | Torus - Cryogenic Tower - Drafting Mechanical | 80d | 2013-09-16 A | 2014-05-13 | 242762010 FS-75d |  | 127d | 2013-10-08 | 2014-02-11 | 41d | 3d | 8/5 M-F w/JLAB Holidays ReBaseline | MECH DES [640 h] | 32,832 | 6,863.94 |  |  |  |  | 0 |  | 24271360 | ELOUADRHIRI L | 1 | 1 | S | LATIFA E | 4211 | Phil | 12-024 | 13-002F | EJ | 13-015 | PR | 14-001 |  |  |
| 242762005 |  | Torus - Cryogenic Tower - Structural Engineering | 10d | 2013-10-01 A | 2014-01-13 | 242762000 FS-40d, 242762000a FS-40d | 50% | 42d | 2014-02-03 | 2014-02-14 | 97d | 28d | 8/5 M-F w/JLAB Holidays ReBaseline | MECH ENG [80 h] | 5,973.6 | 2,113.74 |  |  |  |  | 2986.8 |  | 24271360 | ELOUADRHIRI L | 1 | 1 | H | LATIFA E | 4211 | Phil | 12-024 | 13-002F | EJ | 13-015 | PR | 14-001 |  |  |
| 242762020 |  | Torus - Cryogenic Tower - Drafting Structural | 15d | 2013-10-17 A | 2014-06-04 | 242762015 FS-130d | 50% | 142d | 2014-06-17 | 2014-07-08 | 38d | 0d | 8/5 M-F w/JLAB Holidays ReBaseline | MECH DES [120 h] | 6,156 | 442.59 |  |  |  |  | 3078 |  | 24271360 | ELOUADRHIRI L | 1 | 1 | H | LATIFA E | 4211 | Phil | 12-024 | 13-002F | EJ | 13-015 | PR | 14-001 |  |  |
| 242762025 |  | Torus - Cryogenic Tower - ProjectMgt | 10d | 2013-10-17 A | 2014-06-18 | 242762020 FS-142d | 50% | 152d | 2013-11-22 | 2013-12-09 | 38d | 0d | 8/5 M-F w/JLAB Holidays ReBaseline | MECH ENG [80 h] | 5,973.6 | 403.13 |  |  |  |  | 2986.8 |  | 24271360 | ELOUADRHIRI L | 1 | 1 | H | LATIFA E | 4211 | Phil | 12-024 | 13-002F | EJ | 13-015 | PR | 14-001 |  |  |
| 242762030 |  | Torus - Cryogenic Tower - QA | 15d | 2014-06-19 | 2014-07-10 | 242762025 |  |  |  |  | 38d | 0d | 8/5 M-F w/JLAB Holidays ReBaseline | MECH ENG [120 h] | 8,960.4 |  |  |  |  |  | 0 |  | 24271360 | ELOUADRHIRI L | 1 | 1 | H | LATIFA E | 4211 | Phil | 12-024 | 13-002F | EJ | 13-015 | PR | 14-001 |  |  |
| 242762035 |  | Torus - Cryogenic Tower - Write Specs | 15d | 2014-07-11 | 2014-07-31 | 242762030 |  |  |  |  | 38d | 0d | 8/5 M-F w/JLAB Holidays ReBaseline | MECH ENG [120 h] | 8,960.4 |  |  |  |  |  | 0 |  | 24271360 | ELOUADRHIRI L | 1 | 1 | H | LATIFA E | 4211 | Phil | 12-024 | 13-002F | EJ | 13-015 | PR | 14-001 |  |  |
| 242762040 |  | Torus - Cryogenic Tower - Bid and select vendor | 40d | 2014-08-01 | 2014-09-26 | 242762035 |  |  |  |  | 38d | 0d | 8/5 M-F w/JLAB Holidays ReBaseline | MECH ENG [80 h] | 5,973.6 |  |  |  |  |  | 0 |  | 24271360 | ELOUADRHIRI L | 1 | 1 | H | LATIFA E | 4211 | Phil | 12-024 | 13-002F | EJ | 13-015 | PR | 14-001 |  |  |
| 242762045 |  | Torus - Cryogenic Tower Procurement | 120d | 2014-09-29 | 2015-03-30 | 242762040 |  |  |  |  | 38d | 0d | 8/5 M-F w/JLAB Holidays ReBaseline | PROCUREMENT<$50K 60 NO ESCALATION FY15; PROCUREMENT>$50K 69 NO ESCALATION FY15 | 372,976.13 |  | 372976.13 | 0 | 0 | 100 | 0 |  | 24271365 | ELOUADRHIRI L | 1 | 1 | D | LATIFA E | 4211 | Phil | 12-024 | 13-002F |  | 13-015 | PR | 14-001 |  | PE |
|  | 7 | **1.4.2.7.7 TORUS INSTUMENTATION AND CONTROL** |  | 2013-08-30 | 2015-05-06 |  |  |  |  |  |  |  |  |  |  |  |  |  |  |  |  |  |  |  |  |  |  |  |  |  |  |  |  |  |  |  |  |  |
|  | 1 | **1.4.2.7.7.1 TORUS INSTUMENTATION AND CONTROL** |  | 2013-08-30 | 2015-05-06 |  |  |  |  |  |  |  |  |  |  |  |  |  |  |  |  |  |  |  |  |  |  |  |  |  |  |  |  |  |  |  |  |  |
| 142771000 |  | Re-Baseline Actuals Adjustment | 1d | 2013-08-30 A | 2013-08-30 A |  | 100% |  | 2013-09-03 | 2013-09-03 |  |  |  | PROCUREMENT>$50K 69 NO ESCALATION | 39,181.6 |  | 0 | 39181.6 | 3918160 | 100 | 39181.6 | ADJ |  |  |  |  |  |  |  |  |  |  |  |  |  |  |  |  |
| 242771000 |  | Torus - Instrumentation Controls Design | 55d | 2013-11-01 | 2014-01-31 | 9-140M FS+1d |  |  |  |  | 214d | 0d | 8/5 M-F w/JLAB Holidays ReBaseline | ELEC ENG [36.67 h]; ELEC DES [366.66 h] | 22,473.91 |  |  |  |  |  | 0 |  | 24271322 | ELOUADRHIRI L | 1 | 1 | S | LATIFA E | 4211 | Phil | 12-024 | 13-002F | EJ | 13-015 | PR | 14-001 |  |  |
| 242771010 |  | Torus - Instrumentation Sensors Procurement | 60d | 2013-12-05 | 2014-03-11 | 9-130M FS+228d, 9-140M FS+45d |  |  |  |  | 77d | 13d | 8/5 M-F w/JLAB Holidays ReBaseline | PROCUREMENT<$50K 60 NO ESCALATION FY14; PROCUREMENT>$50K 69 NO ESCALATION FY14 | 145,500 |  | 145500 | 0 | 0 | 100 | 0 |  | 24271330 | ELOUADRHIRI L | 1 | 1 | D | LATIFA E | 4211 | Phil | 12-024 | 13-002F |  | 13-015 | PR |  |  | PE |
| 242771005 |  | Torus - Instrumentation Magnet Protection System Design | 120d | 2014-02-03 | 2014-07-22 | 242771000 |  |  |  |  | 214d | 49d | 8/5 M-F w/JLAB Holidays ReBaseline | ELEC ENG [240 h]; ELEC DES [1400 h] | 93,323.2 |  |  |  |  |  | 0 |  | 24271323 | ELOUADRHIRI L | 1 | 1 | S | LATIFA E | 4211 | Phil | 12-024 | 13-002F | EJ | 13-015 | PR | 14-001 |  |  |
| 242771015 |  | Torus - Instrumentation Controls Procurement Prep | 5d | 2014-10-01 | 2014-10-07 | 242771000, 9-155M |  |  |  |  | 55d | 0d | 8/5 M-F w/JLAB Holidays ReBaseline | ELEC ENG [40 h] | 3,005.2 |  |  |  |  |  | 0 |  | 24271335 | ELOUADRHIRI L | 1 | 1 | H | LATIFA E | 4211 | Phil | 12-024 | 13-002F | EJ | 13-015 | PR | 14-001 |  |  |
| 242771025 |  | Torus - Instrumentation Magnet Protection System Procurement Prep | 5d | 2014-10-01 | 2014-10-07 | 242771005, 9-155M |  |  |  |  | 165d | 0d | 8/5 M-F w/JLAB Holidays ReBaseline | ELEC ENG [40 h] | 3,005.2 |  |  |  |  |  | 0 |  | 24271341 | ELOUADRHIRI L | 1 | 1 | H | LATIFA E | 4211 | Phil | 12-024 | 13-002F | EJ | 13-015 | PR | 14-001 |  |  |
| 242771020 |  | Torus - Instrumentation Controls Procurement | 80d | 2014-10-08 | 2015-02-11 | 242771015 |  |  |  |  | 55d | 0d | 8/5 M-F w/JLAB Holidays ReBaseline | PROCUREMENT<$50K 60 | 36,116.5 |  | 36116.5 | 0 | 0 | 100 | 0 |  | 24271340 | ELOUADRHIRI L | 1 | 1 | D | LATIFA E | 4211 | Phil | 12-024 | 13-002F |  | 13-015 | PR | 14-001 |  | PE |
| 242771030 |  | Torus - Instrumentation Magnet Protection System Procurement | 60d | 2014-10-08 | 2015-01-13 | 242771025 |  |  |  |  | 165d | 110d | 8/5 M-F w/JLAB Holidays ReBaseline | PROCUREMENT<$50K 60; PROCUREMENT>$50K 69 | 278,784.3 |  | 278784.3 | 0 | 0 | 100 | 0 |  | 24271342 | ELOUADRHIRI L | 1 | 1 | D | LATIFA E | 4211 | Phil | 12-024 | 13-002F |  | 13-015 | PR | 14-001 |  | PE |
| 242771035 |  | Torus - Instrumentation Controls Assembly | 120d | 2014-11-05 | 2015-05-06 | 242771020 FS-60d, 242771030 FS-150d |  |  |  |  | 55d | 30d | 8/5 M-F w/JLAB Holidays ReBaseline | ELEC ENG [232 h]; ELEC TECH [2464 h] | 133,213.52 |  |  |  |  |  | 0 |  | 24271345 | ELOUADRHIRI L | 1 | 1 | S | LATIFA E | 4211 | Phil | 12-024 | 13-002F | EJ | 13-015 | PR | 14-001 |  |  |

| ID | WBS | Activity | Duration | Start | Finish | Predecessors | Complete | Remaining | Planned start | Planned finish | Total float | Free float | Calendar | Resources | Cost | Actual cost | Remaining Material Cost Based on % Compl | Claimed Material Cost Based on % Complet | Initial Claimed Material Calc | Claimed Material Divider | MONTHLY EV COST | ReBaseline Actuals Adjustment | LOE Divider | LOE Multiplier | Original Activity ID Rebaseline | PRIOR MONTH EV COST | RESP - Responsibility | STRT%COMP for CM EVM | FNSH%COMP for CM EVM | EVMS Reporting Codes | CAM RESPONSIBLE | 12 GEV MAJOR PROCUREMENT CATAGORY | CR 12-024 | CR 13-002 | BOE Labor | BOE Expenses | CR 13-015 | Post Rebaseline | LOE % Pre Calc | LOE % | CR 14-001 | Activities with Steps | CR 13-004 | BOE Procurement |
| --- | --- | --- | --- | --- | --- | --- | --- | --- | --- | --- | --- | --- | --- | --- | --- | --- | --- | --- | --- | --- | --- | --- | --- | --- | --- | --- | --- | --- | --- | --- | --- | --- | --- | --- | --- | --- | --- | --- | --- | --- | --- | --- | --- | --- |
|  | 8 | **1.4.2.7.8 SOLENOID MAGNET DESIGN/PARTS** |  | 2013-08-30 | 2015-01-05 |  |  |  |  |  |  |  |  |  |  |  |  |  |  |  |  |  |  |  |  |  |  |  |  |  |  |  |  |  |  |  |  |  |  |  |  |  |  |  |
|  | 1 | **1.4.2.7.8.1 SOLENOID MAGNET DESIGN/PARTS** |  | 2013-08-30 | 2015-01-05 |  |  |  |  |  |  |  |  |  |  |  |  |  |  |  |  |  |  |  |  |  |  |  |  |  |  |  |  |  |  |  |  |  |  |  |  |  |  |  |
| 142781000 |  | Re-Baseline Actuals Adjustment | 1d | 2013-08-30 A | 2013-08-30 A |  | 100% |  | 2013-09-03 | 2013-09-03 |  |  |  | PROCUREMENT>$50K 69 NO ESCALATION | 92,282.59 |  | 0 | 92282.59 | 9228259 | 100 | 92282.59 | ADJ |  |  |  |  |  |  |  |  |  |  |  |  |  |  |  |  |  |  |  |  |  |  |
| 242781000LOE |  | Solenoid - Technical Support & Oversite FY13 | 20d | 2013-09-03 A | 2013-09-30 A | 9-130M FS+228d | 100% |  | 2013-10-01 | 2013-10-28 |  |  | 8/5 M-F w/JLAB Holidays ReBaseline | SR STAFF [220.14 h]; SUPPLIES & MATERIALS | 29,171.86 | 25,668.32 |  |  |  |  | 0 |  | 100 | 100 | 24272060LOE | 28352.944 | ELOUADRHIRI L | 1 | 1 | E | LATIFA E | 4211 | 12-024 | 13-002F | EJ | EJ | 13-015 | PR |  |  |  |  |  |  |
| 242781005LOE |  | Solenoid - Technical Support & Oversite FY14 | 247d | 2013-10-01 A | 2014-09-30 | 242781000LOE | 9% | 224d | 2013-11-01 | 2014-10-31 | 58d | 0d | 8/5 M-F w/JLAB Holidays ReBaseline | SR STAFF [2700 h]; SUPPLIES & MATERIALS | 360,980.5 | 30,250.49 |  |  |  |  | 33607.28455 |  | 100 | 100 | 24272065LOE |  | ELOUADRHIRI L | 1 | 1 | E | LATIFA E | 4211 | 12-024 | 13-002F | EJ | EJ | 13-015 | PR | 90.6882591 | 9.31174089 | 14-001 |  |  |  |
| 242781015 |  | Solenoid - Magent Installation Design | 149d | 2013-10-01 A | 2014-05-12 | 9-140M | 20% | 126d | 2013-11-01 | 2014-06-13 | 133d | 0d | 8/5 M-F w/JLAB Holidays ReBaseline | ELEC ENG [200 h]; SCIENTIST [200 h]; SR STAFF [200 h]; MECH DES [800 h]; MECH ENG [400 h] | 125,034 | 19,300.55 |  |  |  |  | 25006.8 |  |  |  | 24272110 |  | ELOUADRHIRI L | 1 | 1 | S | LATIFA E | 4211 |  |  | EJ |  | 13-015 | PR |  |  | 14-001 | ST | 13-004 |  |
| 242781025 |  | Solenoid Commissioning - Design & Documentation | 189d | 2014-03-04 | 2014-11-26 | 9-140M FS+100d |  |  |  |  | 263d | 356d | 8/5 M-F w/JLAB Holidays ReBaseline | SR STAFF [160 h]; MECH ENG [80 h] | 25,224.8 |  |  |  |  |  | 0 |  |  |  | 24272400 |  | ELOUADRHIRI L | 1 | 1 | S | LATIFA E | 4211 |  |  | EJ |  | 13-015 | PR |  |  | 14-001 | ST | 13-004 |  |
| 242781020 |  | Solenoid - Magent Installation Procurements | 120d | 2014-05-13 | 2014-10-30 | 242781015 |  |  |  |  | 133d | 226d | 8/5 M-F w/JLAB Holidays ReBaseline | PROCUREMENT<$50K 60 NO ESCALATION FY15 | 41,276 |  | 41276 | 0 | 0 | 100 | 0 |  |  |  | 24272115 |  | ELOUADRHIRI L | 1 | 1 | D | LATIFA E | 4211 |  |  |  |  | 13-015 | PR |  |  | 14-001 |  | 13-004 | EJ |
| 242781010LOE |  | Solenoid - Technical Support & Oversite FY15 | 59d | 2014-10-01 | 2015-01-05 | 242781005LOE |  |  |  |  | 245d | 338d | 8/5 M-F w/JLAB Holidays ReBaseline | SUPPLIES & MATERIALS; SR STAFF [486.8 h] | 68,890.78 |  |  |  |  |  | 0 |  | 100 | 100 | 24272067LOE |  | ELOUADRHIRI L | 1 | 1 | E | LATIFA E | 4211 | 12-024 | 13-002F | EJ | EJ | 13-015 | PR | 100 | 0 | 14-001 |  |  |  |
|  | 9 | **1.4.2.7.9 SOLENOID CRYOGENICS** |  | 2013-08-30 | 2015-04-15 |  |  |  |  |  |  |  |  |  |  |  |  |  |  |  |  |  |  |  |  |  |  |  |  |  |  |  |  |  |  |  |  |  |  |  |  |  |  |  |
|  | 1 | **1.4.2.7.9.1 SOLENOID CRYOGENICS** |  | 2013-08-30 | 2015-04-15 |  |  |  |  |  |  |  |  |  |  |  |  |  |  |  |  |  |  |  |  |  |  |  |  |  |  |  |  |  |  |  |  |  |  |  |  |  |  |  |
| 142791000 |  | Re-Baseline Actuals Adjustment | 1d | 2013-08-30 A | 2013-08-30 A |  | 100% |  | 2013-09-03 | 2013-09-03 |  |  |  | PROCUREMENT>$50K 69 NO ESCALATION | 5,842.93 |  | 0 | 5842.93 | 584293 | 100 | 5842.93 | ADJ |  |  |  |  |  |  |  |  |  |  |  |  |  |  |  |  |  |  |  |  |  |  |
| 242791000 |  | Solenoid - Thermal Analysis FY13 | 20d | 2013-09-03 A | 2014-01-24 | 9-130M FS+228d |  | 50d | 2013-10-01 | 2013-10-28 | 90d | 0d | 8/5 M-F w/JLAB Holidays ReBaseline | MECH ENG [160 h] | 11,947.2 | 3,307.89 |  |  |  |  | 0 |  |  |  | 24272120 |  | ELOUADRHIRI L | 1 | 1 | S | LATIFA E | 4211 |  |  | EJ |  | 13-015 | PR |  |  |  |  | 13-004 |  |
| 242791000a |  | Solenoid - Thermal Analysis FY14 | 50d | 2013-09-03 A | 2014-01-24 | 242791000 FS-60d |  | 50d | 2013-10-01 | 2013-12-11 | 90d | 0d | 8/5 M-F w/JLAB Holidays ReBaseline | MECH ENG [400 h] | 29,868 | 8,269.71 |  |  |  |  | 0 |  |  |  | 24272120 |  | ELOUADRHIRI L | 1 | 1 | S | LATIFA E | 4211 |  |  | EJ |  | 13-015 | PR |  |  | 14-001 |  | 13-004 |  |
| 242791010 |  | Solenoid - Cryogenic Modes of Operation | 15d | 2013-09-09 A | 2013-11-21 | 242791005 FS-30d | 50% | 15d | 2013-11-19 | 2013-12-11 | 90d | 0d | 8/5 M-F w/JLAB Holidays ReBaseline | MECH ENG [120 h] | 8,960.4 | 4,481.65 |  |  |  |  | 0 |  |  |  | 24272120 | 4480.2 | ELOUADRHIRI L | 1 | 1 | H | LATIFA E | 4211 |  |  | EJ |  | 13-015 | PR |  |  | 14-001 |  | 13-004 |  |
| 242791020 |  | Solenoid - Evaluation of Process Components | 20d | 2013-09-09 A | 2013-12-02 | 242791015 FS-50d | 50% | 20d | 2013-12-10 | 2014-01-16 | 58d | 0d | 8/5 M-F w/JLAB Holidays ReBaseline | MECH ENG [80 h]; MECH TECH [80 h] | 9,759.2 | 4,203.38 |  |  |  |  | 0 |  |  |  | 24272120 | 4879.6 | ELOUADRHIRI L | 1 | 1 | H | LATIFA E | 4211 |  |  | EJ |  | 13-015 | PR |  |  | 14-001 |  | 13-004 |  |
| 242791005 |  | Solenoid - Process P&Is | 30d | 2013-11-01 | 2013-12-16 | 242791000 FS-50d, 242791000a FS-50d |  |  |  |  | 90d | 0d | 8/5 M-F w/JLAB Holidays ReBaseline | MECH DES [120 h]; MECH ENG [120 h] | 15,116.4 |  |  |  |  |  | 0 |  |  |  | 24272120 |  | ELOUADRHIRI L | 1 | 1 | S | LATIFA E | 4211 |  |  | EJ |  | 13-015 | PR |  |  | 14-001 | ST | 13-004 |  |
| 242791015 |  | Solenoid - PDR | 3d | 2013-11-22 | 2013-11-26 | 242791010 |  |  |  |  | 90d | 32d | 8/5 M-F w/JLAB Holidays ReBaseline | MECH ENG [24 h] | 1,792.08 |  |  |  |  |  | 0 |  |  |  | 24272120 |  | ELOUADRHIRI L | 1 | 1 | H | LATIFA E | 4211 |  |  | EJ |  | 13-015 | PR |  |  | 14-001 |  | 13-004 |  |
| 242791025 |  | Solenoid - Current Leads | 23d | 2013-12-03 | 2014-01-14 | 242791020 |  |  |  |  | 58d | 0d | 8/5 M-F w/JLAB Holidays ReBaseline | MECH ENG [92 h]; MECH TECH [92 h] | 11,223.08 |  |  |  |  |  | 0 |  |  |  | 24272120 |  | ELOUADRHIRI L | 1 | 1 | S | LATIFA E | 4211 |  |  | EJ |  | 13-015 | PR |  |  | 14-001 |  | 13-004 |  |
| 242791030 |  | Solenoid - Mechanical Design of the cryogenic can | 120d | 2014-01-15 | 2014-07-03 | 242791025 |  |  |  |  | 58d | 0d | 8/5 M-F w/JLAB Holidays ReBaseline | MECH ENG [480 h]; MECH TECH [480 h] | 58,555.2 |  |  |  |  |  | 0 |  |  |  | 24272120 |  | ELOUADRHIRI L | 1 | 1 | S | LATIFA E | 4211 |  |  | EJ |  | 13-015 | PR |  |  | 14-001 |  | 13-004 |  |
| 242791035 |  | Solenoid - FDR | 1d | 2014-07-07 | 2014-07-07 | 242791030 |  |  |  |  | 58d | 0d | 8/5 M-F w/JLAB Holidays ReBaseline | MECH ENG [8 h] | 597.36 |  |  |  |  |  | 0 |  |  |  | 24272120 |  | ELOUADRHIRI L | 1 | 1 | S | LATIFA E | 4211 |  |  | EJ |  | 13-015 | PR |  |  | 14-001 |  | 13-004 |  |
| 242791040 |  | Solenoid Cryogenics - Write Specifications | 15d | 2014-07-08 | 2014-07-28 | 242791035 |  |  |  |  | 58d | 0d | 8/5 M-F w/JLAB Holidays ReBaseline | MECH ENG [120 h] | 8,960.4 |  |  |  |  |  | 0 |  |  |  | 24272125 |  | ELOUADRHIRI L | 1 | 1 | D | LATIFA E | 4211 |  |  |  | EJ | 13-015 | PR |  |  | 14-001 |  | 13-004 | EJ |
| 242791045 |  | Solenoid Cryogenics - Bid cycle, review and award | 40d | 2014-07-29 | 2014-09-23 | 242791040 |  |  |  |  | 58d | 0d | 8/5 M-F w/JLAB Holidays ReBaseline | MECH ENG [80 h] | 5,973.6 |  |  |  |  |  | 0 |  |  |  | 24272125 |  | ELOUADRHIRI L | 1 | 1 | D | LATIFA E | 4211 |  |  |  | EJ | 13-015 | PR |  |  | 14-001 |  | 13-004 | EJ |
| 242791050 |  | Solenoid Cryogenics - Procurement | 100d | 2014-09-24 | 2015-02-25 | 242791045 |  |  |  |  | 58d | 0d | 8/5 M-F w/JLAB Holidays ReBaseline | PROCUREMENT<$50K 60; PROCUREMENT>$50K 69; SUPPLIES & MATERIALS | 347,750.3 |  | 296155.3 | 0 | 0 | 100 | 0 |  |  |  | 24272125 |  | ELOUADRHIRI L | 1 | 1 | D | LATIFA E | 4211 |  |  |  | EJ | 13-015 | PR |  |  | 14-001 |  | 13-004 | EJ |
| 242791055 |  | Solenoid cryogenics - Installation and Commissioning | 15d | 2015-02-26 | 2015-03-18 | 242791050 |  |  |  |  | 58d | 0d | 8/5 M-F w/JLAB Holidays ReBaseline | MECH ENG [60 h]; MECH TECH [60 h] | 7,319.4 |  |  |  |  |  | 0 |  |  |  | 24272130 |  | ELOUADRHIRI L | 1 | 1 | S | LATIFA E | 4211 |  |  | EJ | EJ | 13-015 | PR |  |  | 14-001 |  | 13-004 |  |
| 242791060 |  | Solenoid cryogenics - Test of system | 20d | 2015-03-19 | 2015-04-15 | 242791055 |  |  |  |  | 58d | 151d | 8/5 M-F w/JLAB Holidays ReBaseline | MECH ENG [80 h]; MECH TECH [80 h] | 9,759.2 |  |  |  |  |  | 0 |  |  |  | 24272130 |  | ELOUADRHIRI L | 1 | 1 | S | LATIFA E | 4211 |  |  | EJ | EJ | 13-015 | PR |  |  | 14-001 |  | 13-004 |  |

Notes:
- 242781015: Steps: Validate Initial Magnetic Design (done); Validate Initial Quench Design (done); Validate Initial Cryogenic Design (done); Validate Initial Structural Design (done); Validate Intermediate Magnetic Design; Validate Intermediate Quench Design; Validate Intermediate Cryogenic Design; Validate Intermediate Structural Design; Validate Final Magnetic Design; Validate Final Quench Design; Validate FinalCryogenic Design; Validate Final Structural Design; Develop Solenoid/Detector Interface Documentation; Develop Solenoid/Cryogenic Interface Documentation; Develop Instrumentation & Controls Interface Documentation; Develop Installation Interface and Plan; Develop Operational Parameters Documentation; Validate & Finalize - Interface Control Documentation; Validate & Finalize - Accepatnce Documentation; Create Design History File
- 242781025: Steps: Develop Plan for Receipt and Acceptance Testing of Solenoid Magnet; Develop Solenoid Commissioning Plan; Complete Receipt and Acceptance Testing of Solenoid Magnet; Complete Solenoid Commissioning Plan; Develop Operational Performance Report
- 242791005: Steps: Solenoid - Process P&Is

| ID | WBS | Activity | Duration | Start | Finish | Predecessors | Complete | Remaining | Planned start | Planned finish | Total float | Free float | Calendar | Resources | Cost | Remaining Material Cost Based on % Compl | Claimed Material Cost Based on % Complet | Initial Claimed Material Calc | Claimed Material Divider | MONTHLY EV COST | ReBaseline Actuals Adjustment | Original Activity ID Rebaseline | RESP - Responsibility | STRT%COMP for CM EVM | FNSH%COMP for CM EVM | EVMS Reporting Codes | CAM RESPONSIBLE | 12 GEV MAJOR PROCUREMENT CATAGORY | Activities with Steps | CR 12-024 | CR 13-002 | BOE Labor | CR 13-015 | Post Rebaseline | CR 14-001 | BOE Procurement | LOE % Pre Calc | LOE % | LOE Divider | LOE Multiplier | Obligated Prior to Rebaseline |
| --- | --- | --- | --- | --- | --- | --- | --- | --- | --- | --- | --- | --- | --- | --- | --- | --- | --- | --- | --- | --- | --- | --- | --- | --- | --- | --- | --- | --- | --- | --- | --- | --- | --- | --- | --- | --- | --- | --- | --- | --- | --- |
|  | 10 | **1.4.2.7.10 SOLENOID INSTRUMENTATION AND CONTROLS** |  | 2013-08-30 | 2015-04-17 |  |  |  |  |  |  |  |  |  |  |  |  |  |  |  |  |  |  |  |  |  |  |  |  |  |  |  |  |  |  |  |  |  |  |  |  |
|  | 1 | **1.4.2.7.10.1 SOLENOID INSTRUMENTATION AND CONTROLS** |  | 2013-08-30 | 2015-04-17 |  |  |  |  |  |  |  |  |  |  |  |  |  |  |  |  |  |  |  |  |  |  |  |  |  |  |  |  |  |  |  |  |  |  |  |  |
| 1427.10000 |  | Re-Baseline Actuals Adjustment | 1d | 2013-08-30 A | 2013-08-30 A |  | 100% |  | 2013-09-03 | 2013-09-03 |  |  |  | PROCUREMENT>$50K 69 NO ESCALATION | 4,331.8 | 0 | 4331.8 | 433180 | 100 | 4331.8 | ADJ |  |  |  |  |  |  |  |  |  |  |  |  |  |  |  |  |  |  |  |  |
| 242710.1015 |  | Solenoid - Instrumentation Controls Design FY13 | 20d | 2013-11-01 | 2013-12-02 | 9-130M FS+228d |  |  |  |  | 55d | 0d | 8/5 M-F w/JLAB Holidays ReBaseline | ELEC ENG [11.11 h]; ELEC DES [111.09 h] | 6,809.1 |  |  |  |  | 0 |  | 24272168 | ELOUADRHIRI L | 1 | 1 | S | LATIFA E | 4211 | ST | 12-024 | 13-002F | EJ | 13-015 | PR |  |  |  |  |  |  |  |
| 242710.1015a |  | Solenoid - Instrumentation Controls Design FY14 | 52d | 2013-12-03 | 2014-02-25 | 242710.1015 |  |  |  |  | 55d | 0d | 8/5 M-F w/JLAB Holidays ReBaseline | ELEC ENG [28.89 h]; ELEC DES [288.89 h] | 17,706.99 |  |  |  |  | 0 |  | 24272168 | ELOUADRHIRI L | 1 | 1 | S | LATIFA E | 4211 | ST | 12-024 | 13-002F | EJ | 13-015 | PR | 14-001 |  |  |  |  |  |  |
| 242710.1000 |  | Solenoid - Instrumentation Magnet Protection System Design | 120d | 2014-02-26 | 2014-08-14 | 242710.1015a, 242710.1015 |  |  |  |  | 144d | 0d | 8/5 M-F w/JLAB Holidays ReBaseline | ELEC ENG [240 h]; ELEC DES [1400 h] | 93,323.2 |  |  |  |  | 0 |  | 24272140 | ELOUADRHIRI L | 1 | 1 | S | LATIFA E | 4211 | ST | 12-024 | 13-002F | EJ | 13-015 | PR | 14-001 |  |  |  |  |  |  |
| 242710.1020 |  | Solenoid - Instrumentation Controls Procurement Prep | 5d | 2014-02-26 | 2014-03-04 | 242710.1015, 242710.1015a |  |  |  |  | 55d | 0d | 8/5 M-F w/JLAB Holidays ReBaseline | ELEC ENG [40 h] | 3,005.2 |  |  |  |  | 0 |  | 24272170 | ELOUADRHIRI L | 1 | 1 | H | LATIFA E | 4211 |  | 12-024 | 13-002F | EJ | 13-015 | PR | 14-001 |  |  |  |  |  |  |
| 242710.1025 |  | Solenoid - Instrumentation Controls Procurement | 79d | 2014-03-05 | 2014-06-24 | 242710.1020 |  |  |  |  | 55d | 0d | 8/5 M-F w/JLAB Holidays ReBaseline | PROCUREMENT<$50K 60 | 36,116.5 | 36116.5 | 0 | 0 | 100 | 0 |  | 24272175 | ELOUADRHIRI L | 1 | 1 | D | LATIFA E | 4211 |  | 12-024 | 13-002F |  | 13-015 | PR | 14-001 | EJ |  |  |  |  |  |
| 242710.1005 |  | Solenoid - Instrumentation Magnet Protection System Procurement Prep | 5d | 2014-08-15 | 2014-08-21 | 242710.1000 |  |  |  |  | 144d | 0d | 8/5 M-F w/JLAB Holidays ReBaseline | ELEC ENG [40 h] | 3,005.2 |  |  |  |  | 0 |  | 24272145 | ELOUADRHIRI L | 1 | 1 | H | LATIFA E | 4211 |  | 12-024 | 13-002F | EJ | 13-015 | PR | 14-001 |  |  |  |  |  |  |
| 242710.1030 |  | Solenoid - Instrumentation Controls Assembly | 160d | 2014-08-21 | 2015-04-17 | 242710.1010 FS-150d, 242710.1025 FS+40d |  |  |  |  | 55d | 148d | 8/5 M-F w/JLAB Holidays ReBaseline | ELEC ENG [232 h]; ELEC TECH [2464 h] | 133,213.52 |  |  |  |  | 0 |  | 24272180 | ELOUADRHIRI L | 1 | 1 | S | LATIFA E | 4211 | ST | 12-024 | 13-002F | EJ | 13-015 | PR | 14-001 |  |  |  |  |  |  |
| 242710.1010 |  | Solenoid - Instrumentation Magnet Protection System Procurement | 60d | 2014-08-22 | 2014-11-14 | 242710.1005 |  |  |  |  | 144d | 89d | 8/5 M-F w/JLAB Holidays ReBaseline | PROCUREMENT<$50K 60; PROCUREMENT>$50K 69 | 312,923.68 | 312923.68 | 0 | 0 | 100 | 0 |  | 24272150 | ELOUADRHIRI L | 1 | 1 | D | LATIFA E | 4211 |  | 12-024 | 13-002F |  | 13-015 | PR | 14-001 | EJ |  |  |  |  |  |
|  | 11 | **1.4.2.7.11 TORUS RISK MITIGATION** |  | 2013-09-03 | 2015-05-12 |  |  |  |  |  |  |  |  |  |  |  |  |  |  |  |  |  |  |  |  |  |  |  |  |  |  |  |  |  |  |  |  |  |  |  |  |
|  | 1 | **1.4.2.7.11.1 ADDITIONAL FNAL COILS FOR TORUS RISK MITIGATION** |  | 2013-11-01 | 2015-01-12 |  |  |  |  |  |  |  |  |  |  |  |  |  |  |  |  |  |  |  |  |  |  |  |  |  |  |  |  |  |  |  |  |  |  |  |  |
| 242711.1010 |  | FNAL - Fabricate CCM #7 | 288d | 2013-11-01 | 2015-01-12 | 242711.1000 FS-270d, 242711.4010 FS-87d, 242711.1005 FS-119d |  |  |  |  | 49d | 0d | 8/5 M-F w/JLAB Holidays ReBaseline | PROCUREMENT>$50K 69 NO ESCALATION FY15 | 132,222.51 | 132222.51 | 0 | 0 | 100 | 0 |  | 24272180 | ELOUADRHIRI L | 1 | 1 | D | LATIFA E | 4211 |  | 12-024 | 13-002F | EJ | 13-015 | PR | 14-001 |  |  |  |  |  |  |
| 242711.1005 |  | FNAL - Fabricate Prototype CCM | 58d | 2013-12-03 | 2014-03-05 | 242711.4005 FS-25d, 242711.4005b FS-25d |  |  |  |  | 76d | 8.5d | 8/5 M-F w/JLAB Holidays ReBaseline | PROCUREMENT<$50K 60; PROCUREMENT>$50K 69 | 132,222.51 | 132222.51 | 0 | 0 | 100 | 0 |  | 24272180 | ELOUADRHIRI L | 1 | 1 | D | LATIFA E | 4211 |  | 12-024 | 13-002F | EJ | 13-015 | PR | 14-001 |  |  |  |  |  |  |
| 242711.1000 |  | Additional FNAL Oversight | 86d | 2014-07-02 | 2014-10-31 | 24271735LOE |  |  |  |  | 72d | 23d | 8/5 M-F w/JLAB Holidays ReBaseline | SR STAFF [480 h] | 57,753.6 |  |  |  |  | 0 |  | 24272180 | ELOUADRHIRI L | 1 | 1 | E | LATIFA E | 4211 |  | 12-024 | 13-002F | EJ | 13-015 | PR | 14-001 |  | 100 | 0 | 100 | 100 |  |
|  | 2 | **1.4.2.7.11.2 ADDITIONAL COIL CASE AND HARDWARE FOR TORUS RISK MITIGATION** |  | 2013-10-01 | 2014-03-04 |  |  |  |  |  |  |  |  |  |  |  |  |  |  |  |  |  |  |  |  |  |  |  |  |  |  |  |  |  |  |  |  |  |  |  |  |
| 242711.2005 |  | Vend Fab 1 Set of Additional Hardware for Cryostat (Cold Mass Shiled, OOPS, Axial Support, MLI, Vacuum Jacket) | 77d | 2013-10-01 A | 2014-03-04 | 9-130M FS+228d |  | 77d | 2013-11-01 | 2014-03-04 | 410d | 385d | 8/5 M-F w/JLAB Holidays ReBaseline | PROCUREMENT<$50K 60 NO ESCALATION FY14 | 45,350 | 45350 | 0 | 0 | 100 | 0 |  | 24272180 | ELOUADRHIRI L | 1 | 1 | D | LATIFA E | 4211 |  | 12-024 | 13-002F | EJ | 13-015 | PR |  |  |  |  |  |  | OB-2 |
|  | 3 | **1.4.2.7.11.3 COIL LN2 TESTING FOR TORUS RISK MITIGATION** |  | 2013-11-01 | 2015-01-12 |  |  |  |  |  |  |  |  |  |  |  |  |  |  |  |  |  |  |  |  |  |  |  |  |  |  |  |  |  |  |  |  |  |  |  |  |
| 242711.3000 |  | LN2 TEST - Procurements Preperation FY13 | 20d | 2013-11-01 | 2013-12-02 | 9-130M FS+228d |  |  |  |  | 67.5d | 0d | 8/5 M-F w/JLAB Holidays ReBaseline | ELEC TECH [18.61 h]; SR STAFF [18.61 h] | 3,112.8 |  |  |  |  | 0 |  | 24272180 | ELOUADRHIRI L | 1 | 1 | S | LATIFA E | 4211 | ST | 12-024 | 13-002F | EJ | 13-015 | PR |  |  |  |  |  |  |  |
| 242711.3000a |  | LN2 TEST - Procurements Preperation FY14 | 23.5d | 2013-12-03 | 2014-01-15 | 242711.3000 |  |  |  |  | 67.5d | 0d | 8/5 M-F w/JLAB Holidays ReBaseline | ELEC TECH [21.39 h]; SR STAFF [21.39 h] | 3,579.6 |  |  |  |  | 0 |  | 24272180 | ELOUADRHIRI L | 1 | 1 | S | LATIFA E | 4211 | ST | 12-024 | 13-002F | EJ | 13-015 | PR | 14-001 |  |  |  |  |  |  |
| 242711.3005 |  | LN2 TEST - Preliminary system set up and integration (One coil LN2 Test) Procurements | 40d | 2013-12-03 | 2014-02-10 | 242711.3000 FS-23d, 242711.3000a FS-23d |  |  |  |  | 78.5d | 11d | 8/5 M-F w/JLAB Holidays ReBaseline | PROCUREMENT<$50K 60 | 30,441.05 | 30441.05 | 0 | 0 | 100 | 0 |  | 24272180 | ELOUADRHIRI L | 1 | 1 | D | LATIFA E | 4211 |  | 12-024 | 13-002F | EJ | 13-015 | PR | 14-001 |  |  |  |  |  |  |
| 242711.3010 |  | LN2 TEST - Mounting of Q heaters and wiring | 16d | 2013-12-03 | 2014-01-06 | 242711.3000 FS-23d, 242711.3000a FS-23d |  |  |  |  | 67.5d | 0d | 8/5 M-F w/JLAB Holidays ReBaseline | ELEC TECH [120 h]; SR STAFF [80 h] | 15,264.4 |  |  |  |  | 0 |  | 24272180 | ELOUADRHIRI L | 1 | 1 | S | LATIFA E | 4211 | ST | 12-024 | 13-002F | EJ | 13-015 | PR | 14-001 |  |  |  |  |  |  |
| 242711.3015 |  | LN2 TEST - Instrumentation general and wiring layout and cabling | 11d | 2014-01-06 | 2014-01-22 | 242711.3010 |  |  |  |  | 67.5d | 0d | 8/5 M-F w/JLAB Holidays ReBaseline | ELEC TECH [80 h]; SR STAFF [60 h] | 10,978.4 |  |  |  |  | 0 |  | 24272180 | ELOUADRHIRI L | 1 | 1 | S | LATIFA E | 4211 | ST | 12-024 | 13-002F | EJ | 13-015 | PR | 14-001 |  |  |  |  |  |  |
| 242711.3025 |  | LN2 TEST - Preliminary system set up and integration (One coil LN2 Test) Labor | 29d | 2014-01-06 | 2014-02-17 | 242711.3010 |  |  |  |  | 73.5d | 6d | 8/5 M-F w/JLAB Holidays ReBaseline | ELEC TECH [200 h]; SR STAFF [100 h] | 21,430 |  |  |  |  | 0 |  | 24272180 | ELOUADRHIRI L | 1 | 1 | S | LATIFA E | 4211 | ST | 12-024 | 13-002F | EJ | 13-015 | PR | 14-001 |  |  |  |  |  |  |
| 242711.3020 |  | LN2 TEST - HV/LV Feedthrough and wirng | 24d | 2014-01-22 | 2014-02-25 | 242711.3015 |  |  |  |  | 67.5d | 0d | 8/5 M-F w/JLAB Holidays ReBaseline | ELEC TECH [200 h]; SR STAFF [80 h] | 19,023.6 |  |  |  |  | 0 |  | 24272180 | ELOUADRHIRI L | 1 | 1 | S | LATIFA E | 4211 | ST | 12-024 | 13-002F | EJ | 13-015 | PR | 14-001 |  |  |  |  |  |  |
| 242711.3030 |  | LN2 TEST - LN2 Testing of Prototype Coil | 10d | 2014-02-25 | 2014-03-11 | 242711.3005, 242711.3020, 242711.1005 FS-15d, 242711.3025 |  |  |  |  | 67.5d | 3.5d | 8/5 M-F w/JLAB Holidays ReBaseline | ELEC TECH [120 h]; SR STAFF [60 h]; SUPPLIES & MATERIALS | 14,921.8 |  |  |  |  | 0 |  | 24272180 | ELOUADRHIRI L | 1 | 1 | S | LATIFA E | 4211 | ST | 12-024 | 13-002F | EJ | 13-015 | PR | 14-001 |  |  |  |  |  |  |
| 242711.3035 |  | LN2 TEST - LN2 Testing of CCM #1 | 10d | 2014-03-17 | 2014-03-28 | 24271695 FS-14d, 242711.3030 |  |  |  |  | 64d | 0d | 8/5 M-F w/JLAB Holidays ReBaseline | ELEC TECH [120 h]; SR STAFF [60 h]; SUPPLIES & MATERIALS | 14,921.8 |  |  |  |  | 0 |  | 24272180 | ELOUADRHIRI L | 1 | 1 | S | LATIFA E | 4211 | ST | 12-024 | 13-002F | EJ | 13-015 | PR | 14-001 |  |  |  |  |  |  |
| 242711.3040 |  | LN2 TEST - LN2 Testing of CCM #2 | 10d | 2014-03-31 | 2014-04-11 | 24271700 FS-11d, 242711.3035 |  |  |  |  | 70d | 0d | 8/5 M-F w/JLAB Holidays ReBaseline | ELEC TECH [120 h]; SR STAFF [60 h]; SUPPLIES & MATERIALS | 14,921.8 |  |  |  |  | 0 |  | 24272180 | ELOUADRHIRI L | 1 | 1 | S | LATIFA E | 4211 | ST | 12-024 | 13-002F | EJ | 13-015 | PR | 14-001 |  |  |  |  |  |  |
| 242711.3045 |  | LN2 TEST - LN2 Testing of CCM #3 | 10d | 2014-04-21 | 2014-05-02 | 242711.3040, 24271705 FS-8d |  |  |  |  | 77d | 0d | 8/5 M-F w/JLAB Holidays ReBaseline | ELEC TECH [120 h]; SR STAFF [60 h]; SUPPLIES & MATERIALS | 14,921.8 |  |  |  |  | 0 |  | 24272180 | ELOUADRHIRI L | 1 | 1 | S | LATIFA E | 4211 | ST | 12-024 | 13-002F | EJ | 13-015 | PR | 14-001 |  |  |  |  |  |  |
| 242711.3050 |  | LN2 TEST - LN2 Testing of CCM #4 | 10d | 2014-05-27 | 2014-06-09 | 242711.3045, 24271710 FS-4d |  |  |  |  | 73d | 0d | 8/5 M-F w/JLAB Holidays ReBaseline | ELEC TECH [120 h]; SR STAFF [60 h]; SUPPLIES & MATERIALS | 14,921.8 |  |  |  |  | 0 |  | 24272180 | ELOUADRHIRI L | 1 | 1 | S | LATIFA E | 4211 | ST | 12-024 | 13-002F | EJ | 13-015 | PR | 14-001 |  |  |  |  |  |  |
| 242711.3055 |  | LN2 TEST - LN2 Testing of CCM #5 | 10d | 2014-07-01 | 2014-07-15 | 242711.3050, 24271715 |  |  |  |  | 63d | 0d | 8/5 M-F w/JLAB Holidays ReBaseline | ELEC TECH [120 h]; SR STAFF [60 h]; SUPPLIES & MATERIALS | 14,921.8 |  |  |  |  | 0 |  | 24272180 | ELOUADRHIRI L | 1 | 1 | S | LATIFA E | 4211 | ST | 12-024 | 13-002F | EJ | 13-015 | PR | 14-001 |  |  |  |  |  |  |
| 242711.3060 |  | LN2 TEST - LN2 Testing of CCM #6 | 10d | 2014-07-29 | 2014-08-11 | 242711.3055, 24271720 |  |  |  |  | 62d | 0d | 8/5 M-F w/JLAB Holidays ReBaseline | ELEC TECH [120 h]; SR STAFF [60 h]; SUPPLIES & MATERIALS | 14,921.8 |  |  |  |  | 0 |  | 24272180 | ELOUADRHIRI L | 1 | 1 | S | LATIFA E | 4211 | ST | 12-024 | 13-002F | EJ | 13-015 | PR | 14-001 |  |  |  |  |  |  |
| 242711.3065 |  | LN2 TEST - LN2 Testing of CCM #7 | 10d | 2014-12-18 | 2015-01-12 | 242711.3060, 242711.1010 FS-10d |  |  |  |  | 49d | 0d | 8/5 M-F w/JLAB Holidays ReBaseline | ELEC TECH [120 h]; SR STAFF [60 h]; SUPPLIES & MATERIALS | 14,921.8 |  |  |  |  | 0 |  | 24272180 | ELOUADRHIRI L | 1 | 1 | S | LATIFA E | 4211 | ST | 12-024 | 13-002F | EJ | 13-015 | PR | 14-001 |  |  |  |  |  |  |

Notes:
- 242710.1015: Steps: Define Operational Parameters & Harware; Develop Process & Control Plan (Analysis, Design & Evaluation); Develop Acceptance Criterion; Develop Receipt & Inspection Process; Develop Specification
- 242710.1015a: Steps: Define Operational Parameters & Harware; Develop Process & Control Plan (Analysis, Design & Evaluation); Develop Acceptance Criterion; Develop Receipt & Inspection Process; Develop Specification
- 242710.1000: Steps: Define Operational Parameters & Harware; Develop Process & Control Plan (Analysis, Design & Evaluation); Develop Acceptance Criterion; Develop Receipt & Inspection Process; Develop Specification
- 242710.1030: Steps: Receipt and Inspection; Assembly & Checkout; Validate and Finalize Protection System Design; Create Design History File
- 242711.3000: Steps: Quench Heaters-Specs; Temp / hall sensors-Specs; Strain gauges-Specs; LV/HV feed through-Specs; QH PSU-Design and spec; Wires, cables and ribbons-Specs; Design of foam box for the test; Plumbing
- 242711.3000a: Steps: Quench Heaters-Specs; Temp / hall sensors-Specs; Strain gauges-Specs; LV/HV feed through-Specs; QH PSU-Design and spec; Wires, cables and ribbons-Specs; Design of foam box for the test; Plumbing
- 242711.3010: Steps: Test of Q Heaters at 77 K; Mounting of Q Heaters to trial coil; Layout of Q heaters wiring; Short test - Coil to GND(Hi Pot, 100V)
- 242711.3015: Steps: Wiring layout; Sensors wiring; Thermal dumps and electrical isolation; Measuring resistances over the actual length; Routing
- 242711.3025: Steps: Room temperature measurement; Set up the calibration for sensors; EHS and safety survey; Test and process control; Set up process and data logging all together at room temperature; Fabricate foam box; Connect plumbing for LN2 and gaseous nitrogen to mixer; Plumb and insulate exhaust lines
- 242711.3020: Steps: wiring the HV and LV feed through; Prepare for the interconnect; Layout the interconnect cable to read out/data logger; De-bugging the cables and check for adequate redundancy
- 242711.3030: Steps: Mounting of Temp /hall sensors; Mounting of Q Heaters; Mounting of strain gauges; Wiring/cable layout and HV/HV feed through wiring to the interconnect; Set up for calibration in the data logger; Set up process and data logging all together at room temperature; Wrap CCM in plastic bag and purge with dry nitrogen; Lift CCM into foam box and Connect instrumentation and plumbing to CCM in box; Monitor Coil temps during test; Disconnect from plumbing & instr; Crane lifted into the shipping crate
- 242711.3035: Steps: Mounting of Temp /hall sensors; Mounting of Q Heaters; Mounting of strain gauges; Wiring/cable layout and HV/HV feed through wiring to the interconnect; Set up for calibration in the data logger; Set up process and data logging all together at room temperature; Wrap CCM in plastic bag and purge with dry nitrogen; Lift CCM into foam box and Connect instrumentation and plumbing to CCM in box; Monitor Coil temps during test; Disconnect from plumbing & instr; Crane lifted into the shipping crate
- 242711.3040: Steps: Mounting of Temp /hall sensors; Mounting of Q Heaters; Mounting of strain gauges; Wiring/cable layout and HV/HV feed through wiring to the interconnect; Set up for calibration in the data logger; Set up process and data logging all together at room temperature; Wrap CCM in plastic bag and purge with dry nitrogen; Lift CCM into foam box and Connect instrumentation and plumbing to CCM in box; Monitor Coil temps during test; Disconnect from plumbing & instr; Crane lifted into the shipping crate
- 242711.3045: Steps: Mounting of Temp /hall sensors; Mounting of Q Heaters; Mounting of strain gauges; Wiring/cable layout and HV/HV feed through wiring to the interconnect; Set up for calibration in the data logger; Set up process and data logging all together at room temperature; Wrap CCM in plastic bag and purge with dry nitrogen; Lift CCM into foam box and Connect instrumentation and plumbing to CCM in box; Monitor Coil temps during test; Disconnect from plumbing & instr; Crane lifted into the shipping crate
- 242711.3050: Steps: Mounting of Temp /hall sensors; Mounting of Q Heaters; Mounting of strain gauges; Wiring/cable layout and HV/HV feed through wiring to the interconnect; Set up for calibration in the data logger; Set up process and data logging all together at room temperature; Wrap CCM in plastic bag and purge with dry nitrogen; Lift CCM into foam box and Connect instrumentation and plumbing to CCM in box; Monitor Coil temps during test; Disconnect from plumbing & instr; Crane lifted into the shipping crate
- 242711.3055: Steps: Mounting of Temp /hall sensors; Mounting of Q Heaters; Mounting of strain gauges; Wiring/cable layout and HV/HV feed through wiring to the interconnect; Set up for calibration in the data logger; Set up process and data logging all together at room temperature; Wrap CCM in plastic bag and purge with dry nitrogen; Lift CCM into foam box and Connect instrumentation and plumbing to CCM in box; Monitor Coil temps during test; Disconnect from plumbing & instr; Crane lifted into the shipping crate
- 242711.3060: Steps: Mounting of Temp /hall sensors; Mounting of Q Heaters; Mounting of strain gauges; Wiring/cable layout and HV/HV feed through wiring to the interconnect; Set up for calibration in the data logger; Set up process and data logging all together at room temperature; Wrap CCM in plastic bag and purge with dry nitrogen; Lift CCM into foam box and Connect instrumentation and plumbing to CCM in box; Monitor Coil temps during test; Disconnect from plumbing & instr; Crane lifted into the shipping crate
- 242711.3065: Steps: Mounting of Temp /hall sensors; Mounting of Q Heaters; Mounting of strain gauges; Wiring/cable layout and HV/HV feed through wiring to the interconnect; Set up for calibration in the data logger; Set up process and data logging all together at room temperature; Wrap CCM in plastic bag and purge with dry nitrogen; Lift CCM into foam box and Connect instrumentation and plumbing to CCM in box; Monitor Coil temps during test; Disconnect from plumbing & instr; Crane lifted into the shipping crate

| ID | WBS | Activity | Type | Duration | Start | Finish | Predecessors | Complete | Remaining | Planned start | Planned finish | Total float | Free float | Calendar | Resources | Cost | Actual cost | Original Activity ID Rebaseline | Remaining Material Cost Based on % Compl | Claimed Material Cost Based on % Complet | Initial Claimed Material Calc | Claimed Material Divider | MONTHLY EV COST | RESP - Responsibility | STRT%COMP for CM EVM | FNSH%COMP for CM EVM | EVMS Reporting Codes | CAM RESPONSIBLE | 12 GEV MAJOR PROCUREMENT CATAGORY | CR 12-024 | CR 13-002 | BOE Labor | CR 13-015 | Post Rebaseline | Obligated Prior to Rebaseline | CR 14-001 | LOE % Pre Calc | LOE % | LOE Divider | LOE Multiplier | PRIOR MONTH EV COST | Calculated Remaining Total Cost | CR 08-048 | CR 08-057 | CR 09-012 | CR 09-022 | CR 10-069 | CR 11-026 | CR 12-012 | CR 12-036 | Milestone Level | CR 07-034 | CR 10-063 | CR 10-074 | CR 11-017 | CR 11-046 | Advance Purchase Plan > 500K | CR 08-016 | CR 08-042 | Activities with Steps | Phil Dev | MARCH!!! | CR 12-001 | CR 11-025 | Specification | CR 12-053 | ReBaseline Actuals Adjustment | CR 13-006 | BOE Expenses | BOE NOTES | BOE Procurement | BOE Adder | SC Magnet Dates | Pat's Code | CR 12-054 |
| --- | --- | --- | --- | --- | --- | --- | --- | --- | --- | --- | --- | --- | --- | --- | --- | --- | --- | --- | --- | --- | --- | --- | --- | --- | --- | --- | --- | --- | --- | --- | --- | --- | --- | --- | --- | --- | --- | --- | --- | --- | --- | --- | --- | --- | --- | --- | --- | --- | --- | --- | --- | --- | --- | --- | --- | --- | --- | --- | --- | --- | --- | --- | --- | --- | --- | --- | --- | --- | --- | --- | --- | --- | --- | --- | --- |
|  | 4 | **1.4.2.7.11.4 ADDITIONAL COPPER SSC AND SOLDERING FOR TORUS RISK MITIGATION** |  |  | 2013-11-01 | 2014-02-04 |  |  |  |  |  |  |  |  |  |  |  |  |  |  |  |  |  |  |  |  |  |  |  |  |  |  |  |  |  |  |  |  |  |  |  |  |  |  |  |  |  |  |  |  |  |  |  |  |  |  |  |  |  |  |  |  |  |  |  |  |  |  |  |  |  |  |  |  |  |
| 242711.4005 |  | Solder conductor for Torus Coil #7 Coil - Procurement |  | 45d | 2013-11-01 | 2014-01-16 | 24271740 FS-60d |  |  |  |  | 76d | 0d | 8/5 M-F w/JLAB Holidays ReBaseline | MECH TECH; ELEC TECH; PROCUREMENT<$50K 60 NO ESCALATION FY14 | 51,498 |  | 24272180 | 51498 | 0 | 0 | 100 | 0 | ELOUADRHIRI L | 1 | 1 | D | LATIFA E | 4211 | 12-024 | 13-002F | EJ | 13-015 | PR | OB-2 |  |  |  |  |  |  |  |  |  |  |  |  |  |  |  |  |  |  |  |  |  |  |  |  |  |  |  |  |  |  |  |  |  |  |  |  |  |  |  |  |
| 242711.4005a |  | Solder conductor for Torus Coil #7 and #8 Coil Labor FY13 |  | 20d | 2013-11-01 | 2013-12-02 | 24271740 FS-60d |  |  |  |  | 76d | 0d | 8/5 M-F w/JLAB Holidays ReBaseline | MECH TECH [17.78 h]; ELEC TECH [17.78 h] | 1,676.83 |  | 24272180 |  |  |  |  | 0 | ELOUADRHIRI L | 1 | 1 | H | LATIFA E | 4211 | 12-024 | 13-002F | EJ | 13-015 | PR |  |  |  |  |  |  |  |  |  |  |  |  |  |  |  |  |  |  |  |  |  |  |  |  |  |  |  |  |  |  |  |  |  |  |  |  |  |  |  |  |  |
| 242711.4010 |  | Solder conductor for Torus Coil #8 |  | 57d | 2013-11-01 | 2014-02-04 | 242711.4005 FS-70d, 242711.4005b FS-70d |  |  |  |  | 79d | 30d | 8/5 M-F w/JLAB Holidays ReBaseline | PROCUREMENT<$50K 60; ELEC TECH [40 h]; SCIENTIST [40 h] | 58,027.59 |  | 24272180 | 53140.79 | 0 | 0 | 100 | 0 | ELOUADRHIRI L | 1 | 1 | D | LATIFA E | 4211 | 12-024 | 13-002F | EJ | 13-015 | PR | OB-2 | 14-001 |  |  |  |  |  |  |  |  |  |  |  |  |  |  |  |  |  |  |  |  |  |  |  |  |  |  |  |  |  |  |  |  |  |  |  |  |  |  |  |
| 242711.4005b |  | Solder conductor for Torus Coil #7 and #8 Coil Labor FY14 |  | 25d | 2013-12-03 | 2014-01-16 | 242711.4005a |  |  |  |  | 76d | 0d | 8/5 M-F w/JLAB Holidays ReBaseline | MECH TECH [22.23 h]; ELEC TECH [22.23 h] | 2,096.04 |  | 24272180 |  |  |  |  | 0 | ELOUADRHIRI L | 1 | 1 | H | LATIFA E | 4211 | 12-024 | 13-002F | EJ | 13-015 | PR |  | 14-001 |  |  |  |  |  |  |  |  |  |  |  |  |  |  |  |  |  |  |  |  |  |  |  |  |  |  |  |  |  |  |  |  |  |  |  |  |  |  |  |
|  | 5 | **1.4.2.7.11.5 SECLAY COIL COLD TESTING FOR TORUS RISK MITIGATION** |  |  | 2013-09-03 | 2015-05-12 |  |  |  |  |  |  |  |  |  |  |  |  |  |  |  |  |  |  |  |  |  |  |  |  |  |  |  |  |  |  |  |  |  |  |  |  |  |  |  |  |  |  |  |  |  |  |  |  |  |  |  |  |  |  |  |  |  |  |  |  |  |  |  |  |  |  |  |  |  |
| 242711.5010 |  | Saclay Cold Tests - Oversight Expenses and Labor FY13 |  | 20d | 2013-09-03 A | 2013-09-30 A | 242711.5000 FS-9d | 100% |  | 2013-10-01 | 2013-10-28 |  |  | 8/5 M-F w/JLAB Holidays ReBaseline | SR STAFF [18.71 h]; TRAVEL | 4,005.58 | 2,181.59 | 24271985 |  |  |  |  | 0 | ELOUADRHIRI L | 1 | 1 | E | LATIFA E | 4211 | 12-024 | 13-002F | EJ | 13-015 | PR |  |  | 94.15204678 | 5.84795321 | 100 | 100 | 3935.976 |  |  |  |  |  |  |  |  |  |  |  |  |  |  |  |  |  |  |  |  |  |  |  |  |  |  |  |  |  |  |  |  |  |  |
| 242711.5010a |  | Saclay Cold Tests - Oversight Expenses and Labor FY14 |  | 247d | 2013-10-01 A | 2014-09-30 | 242711.5010 | 9% | 224d | 2013-11-01 | 2014-10-31 | 229d | 0d | 8/5 M-F w/JLAB Holidays ReBaseline | SR STAFF [231.11 h]; TRAVEL | 50,165.02 | 2,589.33 | 24271985 |  |  |  |  | 4670.36291512 | ELOUADRHIRI L | 1 | 1 | E | LATIFA E | 4211 | 12-024 | 13-002F | EJ | 13-015 | PR |  | 14-001 | 90.6882591 | 9.31174089 | 100 | 100 |  |  |  |  |  |  |  |  |  |  |  |  |  |  |  |  |  |  |  |  |  |  |  |  |  |  |  |  |  |  |  |  |  |  |  |
| 242711.5000 |  | Saclay Cold Tests - Contract Preperation |  | 9d | 2013-11-01 | 2013-11-13 | 9-130M FS+228d |  |  |  |  | 229d | 0d | 8/5 M-F w/JLAB Holidays ReBaseline | SR STAFF [80 h] | 9,625.6 |  | 24271985 |  |  |  |  | 0 | ELOUADRHIRI L | 1 | 1 | H | LATIFA E | 4211 | 12-024 | 13-002F | EJ | 13-015 | PR |  |  |  |  |  |  |  |  |  |  |  |  |  |  |  |  |  |  |  |  |  |  |  |  |  |  |  |  |  |  |  |  |  |  |  |  |  |  |  |  |  |
| 242711.5005 |  | Saclay Cold Tests - Kickoff Meeting |  | 19d | 2013-11-01 | 2013-11-27 | 9-140M FS+23d |  |  |  |  | 346d | 0d | 8/5 M-F w/JLAB Holidays ReBaseline | SR STAFF [80 h]; TRAVEL | 19,944.6 |  | 24271985 |  |  |  |  | 0 | ELOUADRHIRI L | 1 | 1 | S | LATIFA E | 4211 | 12-024 | 13-002F | EJ | 13-015 | PR |  | 14-001 |  |  |  |  |  |  |  |  |  |  |  |  |  |  |  |  |  |  |  |  |  |  |  |  |  |  |  |  |  |  |  |  |  |  |  |  |  |  |  |
| 242711.5015 |  | Saclay Cold Tests - Facility Set-up Phase #1 |  | 118d | 2013-11-01 | 2014-04-30 | 242711.5000 FS-9d, 242711.5005 FS-19d |  |  |  |  | 346d | 0d | 8/5 M-F w/JLAB Holidays ReBaseline | PROCUREMENT<$50K 60; PROCUREMENT>$50K 69 | 103,190 |  | 24271985 | 103190 | 0 | 0 | 100 | 0 | ELOUADRHIRI L | 1 | 1 | D | LATIFA E | 4211 | 12-024 | 13-002F | EJ | 13-015 | PR |  | 14-001 |  |  |  |  |  |  |  |  |  |  |  |  |  |  |  |  |  |  |  |  |  |  |  |  |  |  |  |  |  |  |  |  |  |  |  |  |  |  |  |
| 242711.5020 |  | Saclay Cold Tests - Facility Set-up Phase #2 |  | 118d | 2013-11-01 | 2014-04-30 | 242711.5005 FS-19d, 242711.5015 FS-118d |  |  |  |  | 346d | 0d | 8/5 M-F w/JLAB Holidays ReBaseline | PROCUREMENT>$50K 69; PROCUREMENT<$50K 60 | 338,463.2 |  | 24271985 | 338463.2 | 0 | 0 | 100 | 0 | ELOUADRHIRI L | 1 | 1 | D | LATIFA E | 4211 | 12-024 | 13-002F | EJ | 13-015 | PR |  | 14-001 |  |  |  |  |  |  |  |  |  |  |  |  |  |  |  |  |  |  |  |  |  |  |  |  |  |  |  |  |  |  |  |  |  |  |  |  |  |  |  |
| 242711.5025 |  | Saclay Cold Tests - Cryogenic Tests of Prototype Coil |  | 85d | 2014-04-02 | 2014-07-31 | 242711.5020 FS-21d, 242711.3030 |  |  |  |  | 346d | 439d | 8/5 M-F w/JLAB Holidays ReBaseline | PROCUREMENT>$50K 69 | 134,147 |  | 24271985 | 134147 | 0 | 0 | 100 | 0 | ELOUADRHIRI L | 1 | 1 | D | LATIFA E | 4211 | 12-024 | 13-002F | EJ | 13-015 | PR |  | 14-001 |  |  |  |  |  |  |  |  |  |  |  |  |  |  |  |  |  |  |  |  |  |  |  |  |  |  |  |  |  |  |  |  |  |  |  |  |  |  |  |
| 242711.5010b |  | Saclay Cold Tests - Oversight Expenses and Labor FY15 |  | 75d | 2014-10-01 | 2015-01-28 | 242711.5010a |  |  |  |  | 229d | 322d | 8/5 M-F w/JLAB Holidays ReBaseline | SR STAFF [70.18 h]; TRAVEL | 15,232.88 |  | 24271985 |  |  |  |  | 0 | ELOUADRHIRI L | 1 | 1 | E | LATIFA E | 4211 | 12-024 | 13-002F | EJ | 13-015 | PR |  | 14-001 | 100 | 0 | 100 | 100 |  |  |  |  |  |  |  |  |  |  |  |  |  |  |  |  |  |  |  |  |  |  |  |  |  |  |  |  |  |  |  |  |  |  |  |
| 242711.5030 |  | Saclay Cold Tests - Cryogenic Tests of Coil #7 |  | 85d | 2015-01-13 | 2015-05-12 | 242711.3065 |  |  |  |  | 49d | 0d | 8/5 M-F w/JLAB Holidays ReBaseline | PROCUREMENT>$50K 69 | 134,147 |  | 24271985 | 134147 | 0 | 0 | 100 | 0 | ELOUADRHIRI L | 1 | 1 | D | LATIFA E | 4211 | 12-024 | 13-002F | EJ | 13-015 | PR |  | 14-001 |  |  |  |  |  |  |  |  |  |  |  |  |  |  |  |  |  |  |  |  |  |  |  |  |  |  |  |  |  |  |  |  |  |  |  |  |  |  |  |
|  | 3 | **1.4.3 CONSTRUCTION HALL C** |  |  | 2009-01-02 | 2016-02-03 |  |  |  |  |  |  |  |  |  |  |  |  |  |  |  |  |  |  |  |  |  |  |  |  |  |  |  |  |  |  |  |  |  |  |  |  |  |  |  |  |  |  |  |  |  |  |  |  |  |  |  |  |  |  |  |  |  |  |  |  |  |  |  |  |  |  |  |  |  |
|  | 1 | **1.4.3.1 MAGNET** |  |  | 2009-01-02 | 2016-02-03 |  |  |  |  |  |  |  |  |  |  |  |  |  |  |  |  |  |  |  |  |  |  |  |  |  |  |  |  |  |  |  |  |  |  |  |  |  |  |  |  |  |  |  |  |  |  |  |  |  |  |  |  |  |  |  |  |  |  |  |  |  |  |  |  |  |  |  |  |  |
|  | 1 | **1.4.3.1.1 HB MAGNET** |  |  | 2009-10-14 | 2015-01-05 |  |  |  |  |  |  |  |  |  |  |  |  |  |  |  |  |  |  |  |  |  |  |  |  |  |  |  |  |  |  |  |  |  |  |  |  |  |  |  |  |  |  |  |  |  |  |  |  |  |  |  |  |  |  |  |  |  |  |  |  |  |  |  |  |  |  |  |  |  |
| 143118P1LOE |  | HB Contract Mngmnt for HB Mag |  | 239d | 2009-10-14 A | 2010-09-30 A | 14311000M FS-500d | 100% |  |  |  |  |  |  | TRAVEL; MECH DES [240 h]; MECH ENG [400 h] | 41,592.74 | 37,197.6 |  |  |  |  |  | 41592.740713 | FENKER H | 1 | 1 | E | HOWARD F |  |  |  |  |  |  |  |  |  |  | 100 | 100 |  | 0 | 08-048 | 08-057 | 09-012 | 09-022 | 10-069 | 11-026 | 12-012 | 12-036F |  |  |  |  |  |  |  |  |  |  |  |  |  |  |  |  |  |  |  |  |  |  |  |  |  |
| 14311000M |  | HB- Award Contract for HB Mag | milestone | 0d | 2010-06-07 A | 2010-06-07 A | 122312095 FS+85d | 100% |  | 2010-07-01 | 2010-07-01 |  |  |  |  |  |  |  |  |  |  |  | 0 | FENKER H | 1 | 1 | M | HOWARD F |  |  |  |  |  |  |  |  |  |  |  |  |  |  | 08-048 | 08-057 |  | 09-022 |  |  |  |  | 4 |  |  |  |  |  |  |  |  |  |  |  |  |  |  |  |  |  |  |  |  |  |  |  |  |
| 14311002 |  | HB- Contractor Expenses (FROZEN by CR10-063) |  | 11d | 2010-07-02 A | 2010-07-19 A | 14311000M | 100% |  |  |  |  |  |  | PROCUREMENT<$50K 60 | 18,679.35 |  |  | 0 | 18679.35061 | 1867935.061 | 100 | 18679.35061 | FENKER H | 1 | 1 | P | HOWARD F | 4311 |  |  |  |  |  |  |  |  |  |  |  |  | 0 | 08-048 | 08-057 |  | 09-022 | 10-069 | 11-026 | 12-012 |  |  | 07-034 | 10-063 | 10-074 | 11-017 | 11-046 |  |  |  |  |  |  |  |  |  |  |  |  |  |  |  |  |  |  |  |
| 14311005 |  | HB- Finalize Dsgn for HB Mag (FROZEN by CR10-063) |  | 11d | 2010-07-02 A | 2010-07-19 A | 14311000M | 100% |  |  |  |  |  |  | TRAVEL; PROCUREMENT>$50K 69; PROCUREMENT<$50K 60 | 96,833.39 |  |  | 0 | 92438.252097 | 9243825.2097 | 100 | 96833.39281 | FENKER H | 1 | 1 | P | HOWARD F | 4311 |  |  |  |  |  |  |  |  |  |  |  |  | 0 | 08-048 | 08-057 | 09-012 | 09-022 | 10-069 | 11-026 | 12-012 |  |  |  | 10-063 | 10-074 | 11-017 | 11-046 | APP | 08-016 | 08-042 |  |  |  |  |  |  |  |  |  |  |  |  |  |  |  |  |
| 14311010 |  | HB- Dsgn Review of HB Mag (FROZEN by CR10-063) |  | 11d | 2010-07-02 A | 2010-07-19 A | 14311002, 14311005 | 100% |  |  |  |  |  |  | TRAVEL; MECH ENG [40 h] | 4,831.58 | 2,634 |  |  |  |  |  | 4831.575516 | FENKER H | 1 | 1 | H | HOWARD F |  |  |  |  |  |  |  |  |  |  |  |  |  | 0 | 08-048 | 08-057 | 09-012 | 09-022 | 10-069 | 11-026 | 12-012 |  |  |  | 10-063 | 10-074 | 11-017 | 11-046 |  |  |  |  |  |  |  |  |  |  |  |  |  |  |  |  |  |  |  |
| 14311015 |  | HB- Insulate Superconductor (FROZEN by CR10-063) |  | 11d | 2010-07-02 A | 2010-07-19 A | 14311010 | 100% |  |  |  |  |  |  | PROCUREMENT<$50K 60 | 13,185.42 |  |  | 0 | 13185.422139 | 1318542.2139 | 100 | 13185.422139 | FENKER H | 1 | 1 | H | HOWARD F | 4311 |  |  |  |  |  |  |  |  |  |  |  |  | 0 | 08-048 | 08-057 |  | 09-022 | 10-069 | 11-026 | 12-012 |  |  |  | 10-063 | 10-074 | 11-017 | 11-046 | APP |  |  |  |  |  |  |  |  |  |  |  |  |  |  |  |  |  |  |
| 14311080 |  | Reverse Entry - Change Request 10-063 |  | 11d | 2010-07-02 A | 2010-07-19 A | 14311000M | 100% |  |  |  |  |  |  | PROCUREMENT<$50K 60; PROCUREMENT>$50K 69; MECH ENG [-40 h]; TRAVEL | -133,529.74 | -2,634 |  |  |  |  | 100 |  | FENKER H | 1 | 1 | N/A | HOWARD F |  |  |  |  |  |  |  |  |  |  |  |  |  |  |  |  |  |  | 10-069 | 11-026 | 12-012 |  |  |  | 10-063 | 10-074 | 11-017 | 11-046 |  |  |  |  |  |  |  |  |  |  |  |  |  |  |  |  |  |  |  |
| 14311082 |  | Vend Fab HB Magnet Peg Point #1 Preliminary Design Review |  | 84d | 2010-07-02 A | 2010-10-29 A | 14311080 FS-1d, 14311000M | 100% |  |  |  |  |  |  | PROCUREMENT<$50K 60 NO ESCALATION | 13,521 |  |  | 0 | 13521 | 1352100 | 100 | 13521 | FENKER H | 1 | 1 | P | HOWARD F |  |  |  |  |  |  |  |  |  |  |  |  |  | 0 |  |  |  |  | 10-069 | 11-026 | 12-012 |  |  |  | 10-063 | 10-074 | 11-017 | 11-046 |  |  |  |  |  |  |  |  |  |  |  |  |  |  |  |  |  |  |  |
| 14311082a |  | Vend Fab HB Magnet Peg Point #2 HB Analysis Complete |  | 160d | 2010-07-02 A | 2011-02-28 A | 14311082 FS-84d | 100% |  |  |  |  |  |  | PROCUREMENT>$50K 69 NO ESCALATION; PROCUREMENT<$50K 60 NO ESCALATION | 146,795 |  |  | 0 | 146795 | 14679500 | 100 | 146795 | FENKER H | 1 | 1 | P | HOWARD F | 4311 |  |  |  |  |  |  |  |  |  |  |  |  | 0 |  |  |  |  | 10-069 | 11-026 | 12-012 |  |  |  | 10-063 | 10-074 | 11-017 | 11-046 | APP |  |  |  |  |  |  |  |  |  |  |  |  |  |  |  |  |  |  |
| 14311082b |  | Vend Fab HB Magnet Peg Point #3 Intermediate Design Review |  | 288d | 2010-07-02 A | 2011-08-29 A | 14311082a FS-160d | 100% |  |  |  |  |  |  | PROCUREMENT>$50K 69 NO ESCALATION | 175,768 |  |  | 0 | 175768 | 17576800 | 100 | 175768 | FENKER H | 1 | 1 | P | HOWARD F |  |  |  |  |  |  |  |  |  |  |  |  |  | 0 |  |  |  |  | 10-069 | 11-026 | 12-012 |  |  |  | 10-063 | 10-074 | 11-017 | 11-046 |  |  |  |  |  |  |  |  |  |  |  |  |  |  |  |  |  |  |  |
| 14311084 |  | Vend Fab HB Magnet Peg Point #4 Final Design Review |  | 617d | 2010-07-02 A | 2013-01-31 A | 14311015, 14311082b FS-247d | 100% |  | 2010-07-02 | 2012-12-31 |  |  |  | PROCUREMENT>$50K 69 NO ESCALATION | 169,973 |  |  | 0 | 169973 | 16997300 | 100 | 169973 | FENKER H | 1 | 1 | S | HOWARD F |  |  |  |  |  |  |  |  |  |  |  |  |  | 0 |  |  |  |  | 10-069 | 11-026 | 12-012 |  |  |  | 10-063 | 10-074 | 11-017 | 11-046 |  |  |  | ST | MP | XX |  |  |  |  |  |  |  |  |  |  |  |  |  |
| 14311086 |  | Vend Fab HB Magnet Peg Point #5a HB Cold Mass Complete |  | 678d | 2010-07-02 A | 2013-08-30 A | 14311084 FS-332d, 14311073a FS-332d | 100% |  | 2010-07-02 | 2013-03-29 |  |  |  | PROCUREMENT>$50K 69 NO ESCALATION | 81,838 |  |  | 0 | 81838 | 8183800 | 100 | 81838 | FENKER H | 1 | 1 | P | HOWARD F |  |  |  |  |  |  |  |  |  |  |  |  |  | 81838 |  |  |  |  | 10-069 | 11-026 | 12-012 |  |  |  | 10-063 | 10-074 | 11-017 | 11-046 |  |  |  |  |  |  |  |  |  |  |  |  |  |  |  |  |  |  |  |
| 143118P2LOE |  | HB Contract Mngmnt for HB Mag |  | 248d | 2010-10-01 A | 2011-09-30 A | 143118P1LOE | 100% |  |  |  |  |  |  | MECH DES [80 h]; MECH ENG [400 h]; TRAVEL | 35,449.74 | 30,914.4 |  |  |  |  |  | 35449.74 | FENKER H | 1 | 1 | E | HOWARD F |  |  |  |  |  |  |  |  | 8.46774193 | 91.53225806 | 100 | 100 |  | 0 | 08-048 |  |  | 09-022 | 10-069 | 11-026 | 12-012 | 12-036F |  |  |  |  |  |  |  |  |  |  |  |  |  |  |  |  |  |  |  |  |  |  |  |  |  |
| 14311086a |  | Vend Fab HB Magnet Peg Point #5b HB Cold Mass Complete |  | 432d | 2011-06-30 A | 2013-08-30 A | 14311086 FS-275d, 9-110M FS+184d | 100% |  | 2011-06-30 | 2013-03-29 |  |  |  | PROCUREMENT<$50K 60 NO ESCALATION | 34,053 |  |  | 0 | 34053 | 3405300 | 100 | 34053 | FENKER H | 1 | 1 | P | HOWARD F |  |  |  |  |  |  |  |  |  |  |  |  |  | 34053 |  |  |  |  |  | 11-026 | 12-012 |  |  |  |  | 10-074 | 11-017 | 11-046 |  |  |  |  |  |  |  |  |  |  |  |  |  |  |  |  |  |  |  |
| 14311086b |  | Vend Fab HB Magnet Peg Point #6 Cryostat and Materials Certifications Complete |  | 454d | 2011-06-30 A | 2013-08-30 A | 14311086a FS-275d | 100% |  | 2011-06-30 | 2013-04-30 |  |  |  | PROCUREMENT>$50K 69 NO ESCALATION; PROCUREMENT<$50K 60 NO ESCALATION | 90,781 |  |  | 0 | 90781 | 9078100 | 100 | 90781 | FENKER H | 1 | 1 | P | HOWARD F |  |  |  |  |  |  |  |  |  |  |  |  |  | 90781 |  |  |  |  |  | 11-026 | 12-012 |  |  |  |  | 10-074 | 11-017 | 11-046 |  |  |  |  |  |  |  |  |  |  |  |  |  |  |  |  |  |  |  |
| 14311086c |  | Vend Fab HB Magnet Peg Point #7a HB Magnet Cryostated |  | 540d | 2011-06-30 A | 2013-08-30 A | 14311086b FS-315d | 100% |  |  |  |  |  |  | PROCUREMENT>$50K 69 NO ESCALATION | 64,096.1 |  |  | 0 | 64096.1 | 6409610 | 100 | 64096.1 | FENKER H | 1 | 1 | P | HOWARD F |  |  |  |  |  |  |  |  |  |  |  |  |  | 64096.1 |  |  |  |  |  | 11-026 | 12-012 |  |  |  |  | 10-074 | 11-017 | 11-046 |  |  |  |  |  |  |  |  |  |  |  |  |  |  |  |  |  |  |  |
| 14311073 |  | HB Design Reviews FY11 |  | 245.31d | 2011-08-24 A | 2012-08-20 A | 14311082b FS-40d | 100% |  |  |  |  |  |  | TRAVEL; MECH ENG [33.28 h] | 4,212.36 | 2,325.65 |  |  |  |  |  | 4148.086 | FENKER H | 1 | 1 | H | HOWARD F | 4311 |  |  |  |  |  |  |  |  |  |  |  |  | 0 |  |  |  |  |  | 11-026 | 12-012 |  |  |  |  | 10-074 | 11-017 | 11-046 | APP |  |  |  |  |  | 12-001 |  |  |  |  |  |  |  |  |  |  |  |  |
| 14311073a |  | HB Design Reviews FY12 |  | 246d | 2011-08-24 A | 2012-08-20 A | 14311073 FS-185d | 100% |  |  |  |  |  |  | MECH ENG [6.72 h]; TRAVEL | 862.73 | 469.61 |  |  |  |  |  | 864.3264 | FENKER H | 1 | 1 | H | HOWARD F | 4311 |  |  |  |  |  |  |  |  |  |  |  |  | 0 |  |  |  |  |  | 11-026 | 12-012 |  |  |  |  | 10-074 | 11-017 | 11-046 | APP |  |  |  |  |  | 12-001 |  |  |  |  |  |  |  |  |  |  |  |  |
| 143118P3LOE |  | HB Contract Mngmnt for HB Mag |  | 58d | 2011-10-03 A | 2012-01-02 A | 143118P2LOE | 100% |  | 2011-10-03 | 2011-12-30 |  |  |  | TRAVEL; MECH ENG [93.93 h]; MECH DES [18.79 h] | 8,590.43 | 7,491.48 |  |  |  |  |  | 8590.4359 | FENKER H | 1 | 1 | E | HOWARD F |  |  |  |  |  |  |  |  | 76.51821862 | 23.48178137 | 100 | 100 |  | 0 | 08-048 |  |  | 09-022 | 10-069 | 11-026 | 12-012 | 12-036F |  |  |  |  |  |  |  |  |  |  |  |  |  |  |  |  |  |  |  |  |  |  |  |  |  |
| 14311086d |  | Vend Fab HB Magnet Peg Point #7b HB Magnet Cryostated |  | 454d | 2011-11-01 A | 2013-08-30 A | 14311086c FS-370d, 9-120M | 100% |  |  |  |  |  |  | PROCUREMENT<$50K 60 NO ESCALATION | 19,923.9 |  |  | 0 | 19923.9 | 1992390 | 100 | 19923.9 | FENKER H | 1 | 1 | P | HOWARD F |  |  |  |  |  |  |  |  |  |  |  |  |  | 19923.9 |  |  |  |  |  | 11-026 | 12-012 |  |  |  |  | 10-074 | 11-017 | 11-046 |  |  |  |  |  |  |  |  |  |  |  |  |  |  |  |  |  |  |  |
| 14311086f |  | Vend Fab HB Magnet Peg Point #8 Magnet Complete |  | 554d | 2011-11-01 A | 2013-08-30 A | 14311086d FS-370d | 100% |  | 2011-11-01 | 2014-01-31 |  |  |  | PROCUREMENT<$50K 60 NO ESCALATION; PROCUREMENT>$50K 69 NO ESCALATION | 61,808 |  |  | 0 | 61808 | 6180800 | 100 | 61808 | FENKER H | 1 | 1 | P | HOWARD F |  |  |  |  |  |  |  |  |  |  |  |  |  | 61808 |  |  |  |  |  | 11-026 | 12-012 |  |  |  |  | 10-074 | 11-017 | 11-046 |  |  |  |  |  |  |  |  |  |  |  |  |  |  |  |  |  |  |  |
| 14311086g |  | Vend Fab HB Magnet Peg Point #9 HB Tested and Mapped at MSU and delivery to JLab |  | 628d | 2011-11-01 A | 2013-08-30 A | 14311086f FS-435d | 100% |  | 2011-11-01 | 2014-05-16 |  |  |  | PROCUREMENT>$50K 69 NO ESCALATION | 45,391 |  |  | 0 | 45391 | 4539100 | 100 | 45391 | FENKER H | 1 | 1 | P | HOWARD F |  |  |  |  |  |  |  |  |  |  |  |  |  | 45391 |  |  |  |  |  | 11-026 | 12-012 |  |  |  |  | 10-074 | 11-017 | 11-046 |  |  |  |  |  |  |  | 11-025 |  |  |  |  |  |  |  |  |  |  |  |
| 143118P3LOE5 |  | HB Contract Mngmnt for HB Mag |  | 189d | 2012-01-03 A | 2012-09-28 A | 143118P3LOE | 100% |  |  |  |  |  |  | MECH ENG [320 h]; MECH DES [60 h]; TRAVEL | 31,328.6 | 25,328.6 |  |  |  |  |  | 31328.6 | FENKER H | 1 | 1 | E | HOWARD F |  |  |  |  |  |  |  |  | 10.05291005 | 89.94708994 | 100 | 100 |  | 0 | 08-048 |  |  | 09-022 | 10-069 | 11-026 | 12-012 | 12-036F |  |  |  |  |  |  |  |  |  |  |  |  |  |  |  |  |  |  |  |  |  |  |  |  |  |
| 143118P4LOE |  | HB Contract Mngmnt for HB Mag |  | 248d | 2012-10-01 A | 2013-08-30 A | 143118P3LOE5 | 100% |  | 2012-10-01 | 2013-09-30 |  |  |  | MECH ENG [367.74 h]; MECH DES [73.55 h]; TRAVEL | 37,381 | 30,265.88 |  |  |  |  |  | 37380.994657 | FENKER H | 1 | 1 | E | HOWARD F |  |  |  |  |  |  |  |  | 8.06451612 | 91.93548387 | 100 | 100 |  | 6887.81247 | 08-048 |  |  | 09-022 | 10-069 | 11-026 | 12-012 | 12-036F |  |  |  |  |  |  |  |  |  |  |  |  |  |  | 143118P4LOE |  |  |  |  |  |  |  |  |  |  |
| 14311072 |  | HB Site Inspections FY12 |  | 189d | 2013-05-06 A | 2013-08-30 A | 9-130M, 14311086 FS-130d | 100% |  | 2013-10-08 | 2014-07-15 |  |  |  | TRAVEL | 2,371.37 |  |  |  |  |  |  | 2371.37 | FENKER H | 1 | 1 | H | HOWARD F | 4311 |  |  |  |  |  |  |  |  |  |  |  |  | 1185.685 |  |  |  |  |  | 11-026 |  |  |  |  |  | 10-074 |  |  | APP |  |  |  |  |  |  |  | 14311072 | 12-053 |  |  |  |  |  |  |  |  |  |
| 14311072a |  | HB Site Inspections FY13 |  | 184d | 2013-08-30 A | 2013-08-30 A | 14311072 | 100% |  | 2013-10-31 | 2014-07-31 |  |  |  | TRAVEL | 2,382.3 |  |  |  |  |  |  | 2382.3 | FENKER H | 1 | 1 | H | HOWARD F | 4311 |  |  |  |  |  |  |  |  |  |  |  |  | 2382.3 |  |  |  |  |  | 11-026 |  |  |  |  |  | 10-074 |  |  | APP |  |  |  |  |  |  |  | 14311072a | 12-053 |  |  |  |  |  |  |  |  |  |
| 14311950 |  | Re-Baseline Actuals Adjustment |  | 1d | 2013-08-30 A | 2013-08-30 A |  | 100% |  | 2013-09-03 | 2013-09-03 |  |  |  | PROCUREMENT>$50K 69 NO ESCALATION | 370,024.45 |  |  | 0 | 370024.45 | 37002445 | 100 | 370024.45 |  |  |  |  |  |  |  |  |  |  |  |  |  |  |  |  |  |  |  |  |  |  |  |  |  |  |  |  |  |  |  |  |  |  |  |  |  |  |  |  |  |  |  | ADJ |  |  |  |  |  |  |  |  |
| 24311072 |  | HB Site Inspections FY13 |  | 20d | 2013-09-03 A | 2013-09-30 A | 9-130M FS+228d | 100% |  | 2013-10-01 | 2013-10-28 |  |  | 8/5 M-F w/JLAB Holidays ReBaseline | TRAVEL | 1,185.69 |  | 24311072 |  |  |  |  | 0 | FENKER H | 1 | 1 | U | HOWARD F | 4311 |  |  | PE | 13-015 | PR |  |  |  |  |  |  | 1185.69 |  |  |  |  |  |  | 11-026 |  |  |  |  |  | 10-074 |  |  | APP |  |  |  |  |  |  |  |  | 12-053 |  | 13-006F | PE |  |  |  |  |  |  |
| 24311110 |  | Vend Fab HB Magnet Peg Point #10 Weld back He Vessel Plate; Shield Preassembly; Fab Vac Wall Parts |  | 43d | 2013-09-03 A | 2013-09-23 A | 9-130M FS+228d | 100% |  | 2013-09-03 | 2013-10-31 |  |  | 8/5 M-F w/JLAB Holidays ReBaseline | PROCUREMENT>$50K 69 NO ESCALATION | 73,821 |  | 24311110 | 0 | 73821 | 7382100 | 100 | 0 | FENKER H | 1 | 1 | D | HOWARD F |  |  |  |  | 13-015 | PR | OB |  |  |  |  |  | 73821 |  |  |  |  |  |  | 11-026 | 12-012 |  |  |  |  | 10-074 | 11-017 | 11-046 |  |  |  |  |  |  |  | 11-025 |  |  |  | 13-006 |  | OPEN OBLIGATION | VQ | YES |  |  |  |
| 24311115 |  | Vend Fab HB Magnet Peg Point #11 Close He Vessel; Preassemble Cryostat Vac Wall |  | 62d | 2013-09-03 A | 2013-12-20 | 24311110 FS-43d | 25% | 34d | 2013-09-03 | 2013-11-27 | 261d | 28d | 8/5 M-F w/JLAB Holidays ReBaseline | PROCUREMENT>$50K 69 NO ESCALATION | 37,168 |  | 24311115 | 27876 | 9292 | 929200 | 100 | 0 | FENKER H | 1 | 1 | D | HOWARD F |  |  |  |  | 13-015 | PR | OB |  |  |  |  |  | 9292 |  |  |  |  |  |  | 11-026 |  |  |  |  |  | 10-074 |  |  |  |  |  |  |  |  |  |  |  |  |  | 13-006 |  | OPEN OBLIGATION | VQ | YES | Y |  |  |
| 24311120 |  | Vend Fab HB Magnet Peg Point #12 NDT & Warm Testing; Assemble Shield to He Vessel |  | 77d | 2013-09-03 A | 2014-01-15 | 24311115 FS-62d |  | 44d | 2013-09-03 | 2013-12-20 | 233d | 0d | 8/5 M-F w/JLAB Holidays ReBaseline | PROCUREMENT>$50K 69 NO ESCALATION | 83,471 |  | 24311120 | 83471 | 0 | 0 | 100 | 0 | FENKER H | 1 | 1 | D | HOWARD F |  |  |  |  | 13-015 | PR | OB |  |  |  |  |  |  |  |  |  |  |  |  | 11-026 |  |  |  |  |  | 10-074 |  |  |  |  |  |  |  |  |  |  |  |  |  | 13-006 |  | OPEN OBLIGATION | VQ | YES |  |  |  |
| 24311125 |  | Vend Fab HB Magnet Peg Point #13 Shield Support Assy, Instrumentation & Insulation |  | 77d | 2013-09-03 A | 2014-01-31 | 24311120 FS-77d |  | 55d | 2013-09-03 | 2013-12-20 | 200d | 22d | 8/5 M-F w/JLAB Holidays ReBaseline | PROCUREMENT>$50K 69 NO ESCALATION | 19,769 |  | 24311125 | 19769 | 0 | 0 | 100 | 0 | FENKER H | 1 | 1 | D | HOWARD F |  |  |  |  | 13-015 | PR | OB |  |  |  |  |  |  |  |  |  |  |  |  | 11-026 |  |  |  |  |  | 10-074 |  |  |  |  |  |  |  |  |  |  |  |  |  | 13-006 |  | OPEN OBLIGATION | VQ | YES |  |  |  |
| 24311130 |  | Vend Fab HB Magnet Peg Point #14 Suspend He Vessel/Shield; Complete Vac. Walls 2,3 |  | 98d | 2013-09-03 A | 2014-01-31 | 24311125 FS-77d |  | 55d |  |  | 178d | 43d | 8/5 M-F w/JLAB Holidays ReBaseline | PROCUREMENT<$50K 60 NO ESCALATION | 25,966 |  | 24311130 | 25966 | 0 | 0 | 100 | 0 | FENKER H | 1 | 1 | D | HOWARD F |  |  |  |  | 13-015 | PR | OB |  |  |  |  |  |  |  |  |  |  |  |  | 11-026 |  |  |  |  |  | 10-074 |  |  |  |  |  |  |  |  |  |  |  |  |  | 13-006 |  | OPEN OBLIGATION | VQ | YES |  |  |  |
| 24311135 |  | Vend Fab HB Magnet Peg Point #15 Finish Vac Wall & Support Links |  | 118d | 2013-09-03 A | 2014-02-28 | 24311130 FS-98d |  | 75d |  |  | 135d | 43d | 8/5 M-F w/JLAB Holidays ReBaseline | PROCUREMENT<$50K 60 NO ESCALATION | 22,977 |  | 24311135 | 22977 | 0 | 0 | 100 | 0 | FENKER H | 1 | 1 | D | HOWARD F |  |  |  |  | 13-015 | PR | OB |  |  |  |  |  |  |  |  |  |  |  |  | 11-026 |  |  |  |  |  | 10-074 |  |  |  |  |  |  |  |  |  |  |  |  |  | 13-006 |  | OPEN OBLIGATION | VQ | YES |  |  |  |
| 24311140 |  | Vend Fab HB Magnet Peg Point #16 Finish & Leak Check Cryo Header |  | 139d | 2013-09-03 A | 2014-03-31 | 24311135 FS-118d |  | 96d |  |  | 92d | 43d | 8/5 M-F w/JLAB Holidays ReBaseline | PROCUREMENT>$50K 69 NO ESCALATION; PROCUREMENT<$50K 60 NO ESCALATION | 15,692 |  | 24311140 | 15692 | 0 | 0 | 100 | 0 | FENKER H | 1 | 1 | D | HOWARD F |  |  |  |  | 13-015 | PR | OB |  |  |  |  |  |  |  |  |  |  |  |  | 11-026 |  |  |  |  |  | 10-074 |  |  |  |  |  |  |  |  |  |  |  |  |  | 13-006 |  | OPEN OBLIGATION | VQ | YES |  |  |  |
| 24311145 |  | Vend Fab HB Magnet Peg Point #17 Assemble CCR to Magnet |  | 161d | 2013-09-03 A | 2014-04-30 | 24311140 FS-139d |  | 118d |  |  | 49d | 0d | 8/5 M-F w/JLAB Holidays ReBaseline | PROCUREMENT>$50K 69 NO ESCALATION | 26,314.88 |  | 24311145 | 26314.88 | 0 | 0 | 100 | 0 | FENKER H | 1 | 1 | D | HOWARD F |  |  |  |  | 13-015 | PR | OB |  |  |  |  |  |  |  |  |  |  |  |  | 11-026 |  |  |  |  |  | 10-074 |  |  |  |  |  |  |  |  |  |  |  |  |  | 13-006 |  | OPEN OBLIGATION | VQ | YES |  |  |  |
| 243118P4LOE |  | HB Contract Mngmnt for HB Mag |  | 20d | 2013-09-03 A | 2013-09-30 A | 9-130M FS+228d | 100% |  | 2013-10-01 | 2013-10-28 |  |  | 8/5 M-F w/JLAB Holidays ReBaseline | MECH DES [6.45 h]; TRAVEL; MECH ENG [32.25 h] | 3,363.04 | 2,654.25 | 243118P4LOE |  |  |  |  | 0 | FENKER H | 1 | 1 | E | HOWARD F |  |  |  | PE | 13-015 | PR |  |  |  |  |  |  | 3278.289625 |  | 08-048 |  |  | 09-022 | 10-069 | 11-026 | 12-012 | 12-036F |  |  |  |  |  |  |  |  |  |  |  |  |  |  |  |  |  | 13-006F | PE | OPEN OBLIGATION |  |  |  |  |  |
| 24311072a |  | HB Site Inspections FY14 |  | 183d | 2013-10-01 A | 2014-06-30 | 24311072 |  | 160d | 2013-11-01 | 2014-08-01 | 368d |  | 8/5 M-F w/JLAB Holidays ReBaseline | TRAVEL | 2,458.3 |  | 24311072a |  |  |  |  | 0 | FENKER H | 1 | 1 | U | HOWARD F | 4311 |  |  | PE | 13-015 | PR |  | 14-001 |  |  |  |  |  |  |  |  |  |  |  | 11-026 |  |  |  |  |  | 10-074 |  |  | APP |  |  |  |  |  |  |  |  | 12-053 |  | 13-006F | PE |  |  |  |  |  |  |
| 243118P5LOE |  | HB Contract Mngmnt for HB Mag |  | 247d | 2013-10-01 A | 2014-09-30 | 243118P4LOE | 9% | 224d | 2013-11-01 | 2014-10-31 | 683d | 0d | 8/5 M-F w/JLAB Holidays ReBaseline | TRAVEL; MECH ENG [280 h]; MECH DES [40 h] | 32,246.7 | 2,137.94 | 243118P5LOE |  |  |  |  | 3002.16777 | FENKER H | 1 | 1 | E | HOWARD F |  |  |  | PE | 13-015 | PR |  | 14-001 | 90.6882591 | 9.31174089 | 100 | 100 |  |  | 08-048 |  |  | 09-022 | 10-069 | 11-026 | 12-012 | 12-036 |  |  |  |  |  |  |  |  |  |  |  |  |  |  |  |  |  | 13-006 | PE |  |  |  |  |  |  |
| 24311150 |  | Vend Fab HB Magnet Peg Point #18 Connect Leads, Instr. He Vessel, Leak Check Cryo, Finish Shield Conn. |  | 139d | 2013-11-01 | 2014-05-30 | 24311145 FS-118d |  |  |  |  | 49d | 0d | 8/5 M-F w/JLAB Holidays ReBaseline | PROCUREMENT>$50K 69 NO ESCALATION | 50,515.11 |  | 24311150 | 50515.11 | 0 | 0 | 100 | 0 | FENKER H | 1 | 1 | D | HOWARD F |  |  |  |  | 13-015 | PR |  |  |  |  |  |  |  |  |  |  |  |  |  | 11-026 |  |  |  |  |  | 10-074 |  |  |  |  |  |  |  |  |  |  |  |  |  | 13-006 |  | OPEN OBLIGATION | VQ | YES |  |  |  |
| 24311155 |  | Vend Fab HB Magnet Peg Point #19 Finish Insul & Vac; Leak Check; Fab shipping structure |  | 160d | 2013-11-01 | 2014-06-30 | 24311150 FS-139d |  |  |  |  | 49d | 0d | 8/5 M-F w/JLAB Holidays ReBaseline | PROCUREMENT>$50K 69 NO ESCALATION | 33,594 |  | 24311155 | 33594 | 0 | 0 | 100 | 0 | FENKER H | 1 | 1 | D | HOWARD F |  |  |  |  | 13-015 | PR |  |  |  |  |  |  |  |  |  |  |  |  |  | 11-026 |  |  |  |  |  | 10-074 |  |  |  |  |  |  |  |  |  |  |  |  |  | 13-006 |  | OPEN OBLIGATION | VQ | YES |  |  |  |
| 24311160 |  | Vend Fab HB Magnet Peg Point #20 Crate & Deliver HB Magnet to JLab |  | 182d | 2013-11-01 | 2014-07-31 | 24311155 FS-160d |  |  |  |  | 49d | 0d | 8/5 M-F w/JLAB Holidays ReBaseline | PROCUREMENT>$50K 69 NO ESCALATION | 13,458 |  | 24311160 | 13458 | 0 | 0 | 100 | 0 | FENKER H | 1 | 1 | D | HOWARD F |  |  |  |  | 13-015 | PR |  |  |  |  |  |  |  |  |  |  |  |  |  | 11-026 |  |  |  |  |  | 10-074 |  |  |  |  |  |  |  |  |  |  |  |  |  | 13-006 |  | OPEN OBLIGATION | VQ | YES | Y |  |  |
| 24311165 |  | Vend Fab HB Magnet Peg Point #21 Aceptance, Setup, Testing, and Mapping at JLab |  | 224d | 2013-11-01 | 2014-09-30 | 24311160 FS-182d |  |  |  |  | 304d | 0d | 8/5 M-F w/JLAB Holidays ReBaseline | PROCUREMENT>$50K 69 NO ESCALATION | 35,345 |  | 24311165 | 35345 | 0 | 0 | 100 | 0 | FENKER H | 1 | 1 | D | HOWARD F |  |  |  |  | 13-015 | PR |  |  |  |  |  |  |  |  |  |  |  |  |  | 11-026 |  |  |  |  |  | 10-074 |  |  |  |  |  |  |  |  |  |  |  |  |  | 13-006 |  | OPEN OBLIGATION | VQ | YES |  |  |  |
| 24311168 |  | Vend Fab HB Magnet Contract Closeout |  | 128d | 2014-04-01 | 2014-09-30 | 24311165 FS-128d |  |  |  |  | 304d |  | 8/5 M-F w/JLAB Holidays ReBaseline | PROCUREMENT>$50K 69 NO ESCALATION | 80,000 |  | 24311165 | 80000 | 0 | 0 | 100 | 0 | FENKER H | 1 | 1 | D | HOWARD F |  |  |  |  | 13-015 | PR |  |  |  |  |  |  |  |  |  |  |  |  |  | 11-026 |  |  |  |  |  | 10-074 |  |  |  |  |  |  |  |  |  |  |  |  |  | 13-006 |  | OPEN OBLIGATION | VQ | YES |  |  |  |
| 24311170 |  | HB- Factory Mag Test of HB Mag |  | 41d | 2014-05-16 | 2014-07-15 | 24311120 FS+85d |  |  |  |  | 358d |  | 8/5 M-F w/JLAB Holidays ReBaseline | MECH ENG [40 h]; TRAVEL; MECH DES [40 h] | 7,530.5 |  | 24311170 |  |  |  |  | 0 | FENKER H | 1 | 1 | H | HOWARD F |  |  |  | PE | 13-015 | PR |  | 14-001 |  |  |  |  |  |  |  |  |  |  | 10-069 | 11-026 |  | 12-036 |  |  | 10-063 | 10-074 |  |  |  |  |  |  |  |  |  |  |  |  |  | 13-006 | PE |  |  |  |  |  |  |
| 24311071 |  | HB Drawing Validation |  | 100d | 2014-08-01 | 2014-12-23 | 24311160 |  |  |  |  | 246d |  | 8/5 M-F w/JLAB Holidays ReBaseline | MECH DES [480 h] | 24,624 |  | 24311071 |  |  |  |  | 0 | FENKER H | 1 | 1 | S | HOWARD F | 4311 |  |  | PE | 13-015 | PR |  | 14-001 |  |  |  |  |  |  | 08-048 |  | 09-012 | 09-022 | 10-069 | 11-026 |  |  |  |  |  | 10-074 |  |  | APP | 08-016 |  | ST |  |  |  |  |  |  |  | 13-006 |  |  |  |  |  | Pat |  |
| 243118P6LOE |  | HB Contract Mngmnt for HB Mag |  | 59d | 2014-10-01 | 2015-01-05 | 243118P5LOE |  |  |  |  | 683d | 745d | 8/5 M-F w/JLAB Holidays ReBaseline | TRAVEL; MECH ENG [120 h] | 11,540.15 |  | 243118P6LOE |  |  |  |  | 0 | FENKER H | 1 | 1 | E | HOWARD F |  |  |  | PE | 13-015 | PR |  | 14-001 | 100 | 0 | 100 | 100 |  |  | 08-048 |  |  | 09-022 | 10-069 | 11-026 | 12-012 | 12-036 |  |  |  |  |  |  |  |  |  |  |  |  |  |  |  |  |  | 13-006 | PE |  |  |  |  |  |  |
| 24311077 |  | Finducialize Magnet CL of SHMS HB Magnet |  | 1d | 2014-10-28 | 2014-10-28 | 28231000 |  |  |  |  | 304d | 0d | 8/5 M-F w/JLAB Holidays ReBaseline | MECH DES [8 h]; MECH TECH [32 h] | 1,924.64 |  | 24311077 |  |  |  |  | 0 | FENKER H | 1 | 1 | H | HOWARD F |  |  |  | EJ | 13-015 | PR |  | 14-001 |  |  |  |  |  |  | 08-048 |  | 09-012 | 09-022 | 10-069 | 11-026 | 12-012 | 12-036 |  |  | 10-063 | 10-074 | 11-017 | 11-046 |  |  |  |  |  |  |  |  |  |  |  | 13-006 |  |  |  |  |  |  | 12-054 |

Notes:
- 14311084: Steps: Analysis of Pressure Vessels (done); Vessel Materials Certifications (done); Vessel Components Materials Traceability (done); Vessel weld design & analysis (done); Pressure Analysis complete (MS C1-C9) (done); DC System Analysis complete (done); Instrumentation design (done); Final Design Review (done); Magnet Traveler complete (manufacturing plan) (done); Stress Analysis complete (done); Cold Mass Components Complete (done)
- 24311071: Steps: 1st 25% of vendor-supplied drawings checked; 2nd 25% of vendor-supplied drawings checked; 3rd 25% of vendor-supplied drawings checked; 4th 25% of vendor-supplied drawings checked

| ID | WBS | Activity | Type | Duration | Start | Finish | Predecessors | Complete | Remaining | Planned start | Planned finish | Total float | Free float | Constraint | Calendar | Resources | Cost | Actual cost | LOE Divider | LOE Multiplier | Calculated Remaining Total Cost | MONTHLY EV COST | RESP - Responsibility | STRT%COMP for CM EVM | FNSH%COMP for CM EVM | EVMS Reporting Codes | CAM RESPONSIBLE | CR 08-058 | CR 12-012 | CR 08-048 | CR 09-022 | CR 10-067 | CR 10-069 | CR 11-026 | CR 13-006 | Remaining Material Cost Based on % Compl | Claimed Material Cost Based on % Complet | Initial Claimed Material Calc | Claimed Material Divider | CR 07-034 | 12 GEV MAJOR PROCUREMENT CATAGORY | CR 09-041 | CR 09-012 | CR 11-046 | CR 12-003 | Advance Purchase Plan > 500K | CR 10-001 | CR 08-016 | Pat's Code | CR 10-063 | CR 12-036 | Milestone Level | LOE % Pre Calc | LOE % | Schedule Contingency | Activities with Steps | Phil Dev | Specification | ReBaseline Actuals Adjustment | BOE NOTES | Original Activity ID Rebaseline | SC Magnet Dates | BOE Procurement | BOE Adder | CR 13-015 | Post Rebaseline | Obligated Prior to Rebaseline | CR 12-054 | PRIOR MONTH EV COST | BOE Labor | BOE Expenses | CR 14-001 |
| --- | --- | --- | --- | --- | --- | --- | --- | --- | --- | --- | --- | --- | --- | --- | --- | --- | --- | --- | --- | --- | --- | --- | --- | --- | --- | --- | --- | --- | --- | --- | --- | --- | --- | --- | --- | --- | --- | --- | --- | --- | --- | --- | --- | --- | --- | --- | --- | --- | --- | --- | --- | --- | --- | --- | --- | --- | --- | --- | --- | --- | --- | --- | --- | --- | --- | --- | --- | --- | --- | --- | --- | --- |
|  | 2 | **1.4.3.1.2 Q-1 QUADRUPOLE** |  |  | 2009-01-02 | 2015-12-22 |  |  |  |  |  |  |  |  |  |  |  |  |  |  |  |  |  |  |  |  |  |  |  |  |  |  |  |  |  |  |  |  |  |  |  |  |  |  |  |  |  |  |  |  |  |  |  |  |  |  |  |  |  |  |  |  |  |  |  |  |  |  |  |  |  |  |
| 14312909LOE |  | Q1- FY09 Proj Mngmnt H-C upgrade |  | 189d | 2009-01-02 A | 2009-09-30 A | 14312909LOEX | 100% |  |  |  |  |  |  |  | SCIENTIST [337.15 h] | 21,665.26 | 21,665.26 | 100 | 100 | 0 | 21665.259 | FENKER H | 1 | 1 | E | HOWARD F | 08-058 | 12-012 |  |  |  |  |  |  |  |  |  |  |  |  |  |  |  |  |  |  |  |  |  |  |  |  |  |  |  |  |  |  |  |  |  |  |  |  |  |  |  |  |  |  |  |
| 143128P1LOE |  | Q1- P-1 Contract Mngmnt for Q1 |  | 140d | 2009-03-16 A | 2009-09-30 A | 14312909LOEX FS+49d | 100% |  |  |  |  |  |  |  | MECH ENG [108 h]; MECH DES [72 h]; TRAVEL | 12,603.52 | 10,047.96 | 100 | 100 | 0 | 12603.52 | FENKER H | 1 | 1 | E | HOWARD F |  | 12-012 | 08-048 | 09-022 | 10-067 | 10-069 | 11-026 | 13-006F |  |  |  |  |  |  |  |  |  |  |  |  |  |  |  |  |  |  |  |  |  |  |  |  |  |  |  |  |  |  |  |  |  |  |  |  |  |
| 14312002 |  | Q1- Contractor Expenses (Frozen and Reversed by Activity 14312011 per CR 09-041) |  | 1d | 2009-08-03 A | 2009-08-03 A | 9-090M FS+108d | 100% |  |  |  |  |  |  |  | PROCUREMENT>$50K 69 | 20,231.53 |  |  |  | 0 | 20231.53459 | FENKER H | 1 | 1 | H | HOWARD F |  |  | 08-048 |  |  |  |  |  | 0 | 20231.53459 | 2023153.459 | 100 | 07-034 | 4312 | 09-041 |  |  |  |  |  |  |  |  |  |  |  |  |  |  |  |  |  |  |  |  |  |  |  |  |  |  |  |  |  |  |
| 14312011 |  | Reverse Entry for Activities 14312002, 14312010 and 14312010a per CR 09-041 |  | 1d | 2009-08-03 A | 2009-08-03 A | 9-090M FS+206d | 100% |  |  |  |  |  |  |  | TRAVEL; PROCUREMENT>$50K 69 | -23,896.35 |  |  |  |  |  | FENKER H | 1 | 1 | H | HOWARD F |  |  |  |  |  |  |  |  |  |  |  | 100 |  | 4312 | 09-041 |  |  |  |  |  |  |  |  |  |  |  |  |  |  |  |  |  |  |  |  |  |  |  |  |  |  |  |  |  |  |
| 14312015 |  | Vend Fab Q1 Procure Materials |  | 10d | 2009-08-03 A | 2009-08-14 A | 9-090M FS+206d | 100% |  |  |  |  |  |  |  | PROCUREMENT>$50K 69; PROCUREMENT<$50K 60 | 108,588.4 |  |  |  | 0 | 108588.4 | FENKER H | 1 | 1 | P | HOWARD F |  | 12-012 | 08-048 | 09-022 |  | 10-069 | 11-026 |  | 0 | 108588.4 | 10858840 | 100 |  | 4312 | 09-041 | 09-012 | 11-046 | 12-003 |  |  |  |  |  |  |  |  |  |  |  |  |  |  |  |  |  |  |  |  |  |  |  |  |  |  |  |
| 14312020 |  | Vend Fab Q1 Completion of Magnetic and Stress Analysis |  | 162d | 2009-08-03 A | 2010-03-31 A | 9-090M FS+206d | 100% |  |  |  |  |  |  |  | PROCUREMENT>$50K 69 NO ESCALATION | 54,294.2 |  |  |  | 0 | 54294.2 | FENKER H | 1 | 1 | P | HOWARD F |  | 12-012 | 08-048 | 09-022 |  | 10-069 | 11-026 |  | 0 | 54294.2 | 5429420 | 100 |  | 4312 | 09-041 | 09-012 | 11-046 | 12-003 | APP | 10-001A |  |  |  |  |  |  |  |  |  |  |  |  |  |  |  |  |  |  |  |  |  |  |  |  |  |
| 14312025 |  | Vend Fab Q1 Completion of Trial Wind |  | 367d | 2009-08-03 A | 2011-01-28 A | 9-090M FS+206d | 100% |  |  |  |  |  |  |  | PROCUREMENT>$50K 69 NO ESCALATION | 54,294.2 |  |  |  | 0 | 54294.2 | FENKER H | 1 | 1 | P | HOWARD F |  | 12-012 | 08-048 | 09-022 |  | 10-069 | 11-026 |  | 0 | 54294.2 | 5429420 | 100 |  | 4312 | 09-041 | 09-012 | 11-046 | 12-003 | APP | 10-001A | 08-016 |  |  |  |  |  |  |  |  |  |  |  |  |  |  |  |  |  |  |  |  |  |  |  |  |
| 14312032 |  | Vend Fab Q1 Completion of Preliminary Design Review |  | 230d | 2009-08-03 A | 2010-07-07 A | 9-090M FS+206d | 100% |  |  |  |  |  |  |  | PROCUREMENT>$50K 69 NO ESCALATION | 108,588.4 |  |  |  | 0 | 108588.4 | FENKER H | 1 | 1 | P | HOWARD F |  | 12-012 | 08-048 | 09-022 |  | 10-069 | 11-026 |  | 0 | 108588.4 | 10858840 | 100 |  | 4312 | 09-041 | 09-012 | 11-046 | 12-003 | APP | 10-001A |  |  |  |  |  |  |  |  |  |  |  |  |  |  |  |  |  |  |  |  |  |  |  |  |  |
| 14312036 |  | Vend Fab Q1 Completion of Cold Mass Components (Frozen Per CR12-003) |  | 560d | 2009-08-03 A | 2011-11-01 A | 9-090M FS+206d | 100% |  |  |  |  |  |  |  | PROCUREMENT>$50K 69 NO ESCALATION | 54,294.2 |  |  |  | 0 | 54294.2 | FENKER H | 1 | 1 | P | HOWARD F |  | 12-012 | 08-048 | 09-022 | 10-067 | 10-069 | 11-026 |  | 0 | 54294.2 | 5429420 | 100 |  | 4312 | 09-041 | 09-012 | 11-046 | 12-003 | APP | 10-001A | 08-016 |  |  |  |  |  |  |  |  |  |  |  |  |  |  |  |  |  |  |  |  |  |  |  |  |
| 14312040 |  | Vend Fab Q1 Completion of Cold Mass Assembly (Frozen Per CR12-003) |  | 560d | 2009-08-03 A | 2011-11-01 A | 9-090M FS+206d | 100% |  |  |  |  |  |  |  | PROCUREMENT>$50K 69 NO ESCALATION | 108,588.4 |  |  |  | 0 | 108588.4 | FENKER H | 1 | 1 | P | HOWARD F |  | 12-012 | 08-048 | 09-022 | 10-067 | 10-069 | 11-026 |  | 0 | 108588.4 | 10858840 | 100 |  | 4312 | 09-041 | 09-012 | 11-046 | 12-003 | APP | 10-001A | 08-016 |  |  |  |  |  |  |  |  |  |  |  |  |  |  |  |  |  |  |  |  |  |  |  |  |
| 14312041 |  | Vend Fab Q1 Warm Testing Complete (Frozen Per CR12-003) |  | 560d | 2009-08-03 A | 2011-11-01 A | 9-090M FS+206d | 100% |  |  |  |  |  |  |  | PROCUREMENT>$50K 69 NO ESCALATION | 108,588.4 |  |  |  | 0 | 108588.4 | FENKER H | 1 | 1 | P | HOWARD F |  | 12-012 |  |  | 10-067 | 10-069 | 11-026 |  | 0 | 108588.4 | 10858840 | 100 |  | 4312 |  |  | 11-046 | 12-003 | APP |  |  | Pat |  |  |  |  |  |  |  |  |  |  |  |  |  |  |  |  |  |  |  |  |  |  |  |
| 14312042 |  | Vend Fab Q1 Completion of Final Design Review |  | 534d | 2009-08-03 A | 2011-09-26 A | 9-090M | 100% |  |  |  |  |  |  |  | PROCUREMENT>$50K 69 NO ESCALATION | 54,294.2 |  |  |  | 0 | 54294.2 | FENKER H | 1 | 1 | P | HOWARD F |  | 12-012 | 08-048 | 09-022 | 10-067 | 10-069 | 11-026 |  | 0 | 54294.2 | 5429420 | 100 |  |  | 09-041 |  | 11-046 | 12-003 |  | 10-001A |  |  |  |  |  |  |  |  |  |  |  |  |  |  |  |  |  |  |  |  |  |  |  |  |  |
| 14312045 |  | Vend Fab Q1 Completion of Cryostat Components (Frozen Per CR12-003) |  | 560d | 2009-08-03 A | 2011-11-01 A | 9-090M | 100% |  |  |  |  |  |  |  | PROCUREMENT>$50K 69 NO ESCALATION | 108,588.4 |  |  |  | 0 | 108588.4 | FENKER H | 1 | 1 | P | HOWARD F |  | 12-012 | 08-048 | 09-022 | 10-067 | 10-069 | 11-026 |  | 0 | 108588.4 | 10858840 | 100 |  | 4312 | 09-041 |  | 11-046 | 12-003 | APP | 10-001A |  |  |  |  |  |  |  |  |  |  |  |  |  |  |  |  |  |  |  |  |  |  |  |  |  |
| 14312046 |  | Vend Fab Q1 Completion of Cryostat Assembly |  | 1075d | 2009-08-03 A | 2013-08-30 A | 14315031M FS-658d, 14312045a FS-936d, 9-090M FS+206d | 100% |  | 2009-08-03 | 2013-11-27 |  |  |  |  | PROCUREMENT>$50K 69 NO ESCALATION | 54,294.2 |  |  |  | 54294.2 | 54294.2 | FENKER H | 1 | 1 | P | HOWARD F |  | 12-012 |  |  | 10-067 | 10-069 | 11-026 |  | 0 | 54294.2 | 5429420 | 100 |  |  | 09-041 |  | 11-046 | 12-003 |  | 10-001A |  |  | 10-063 | 12-036F |  |  |  |  |  |  |  |  |  |  |  |  |  |  |  |  |  |  |  |  |  |
| 14312047 |  | Vend Fab Q1 Completion of Magnet Assembly |  | 1113d | 2009-08-03 A | 2013-08-30 A | 14312046 FS-884d | 100% |  | 2009-08-03 | 2014-01-31 |  |  |  |  | PROCUREMENT>$50K 69 NO ESCALATION | 54,294.2 |  |  |  | 54294.2 | 54294.2 | FENKER H | 1 | 1 | P | HOWARD F |  | 12-012 |  |  | 10-067 | 10-069 | 11-026 |  | 0 | 54294.2 | 5429420 | 100 |  |  | 09-041 |  | 11-046 | 12-003 |  | 10-001A |  |  |  | 12-036F |  |  |  |  |  |  |  |  |  |  |  |  |  |  |  |  |  |  |  |  |  |
| 14312048 |  | Vend Fab Q1 Completion of Factory Tests by Vendor |  | 1113d | 2009-08-03 A | 2013-08-30 A | 14312047 FS-927d, 14315038 FS-743d | 100% |  | 2009-08-03 | 2014-01-31 |  |  |  |  | PROCUREMENT>$50K 69 NO ESCALATION | 54,294.2 |  |  |  | 54294.2 | 54294.2 | FENKER H | 1 | 1 | P | HOWARD F |  | 12-012 |  |  | 10-067 | 10-069 | 11-026 |  | 0 | 54294.2 | 5429420 | 100 |  |  | 09-041 |  | 11-046 | 12-003 |  | 10-001A |  |  | 10-063 | 12-036F |  |  |  |  |  |  |  |  |  |  |  |  |  |  |  |  |  |  |  |  |  |
| 14312050 |  | Vend Fab Q1 Magnet System Delivery |  | 1117d | 2009-08-03 A | 2013-08-30 A | 14312048 FS-969d | 100% |  | 2009-08-03 | 2014-02-06 |  |  |  |  | PROCUREMENT>$50K 69 NO ESCALATION | 54,294.2 |  |  |  | 54294.2 | 54294.2 | FENKER H | 1 | 1 | P | HOWARD F |  | 12-012 | 08-048 | 09-022 | 10-067 | 10-069 | 11-026 |  | 0 | 54294.2 | 5429420 | 100 |  |  | 09-041 | 09-012 | 11-046 | 12-003 |  | 10-001A |  |  |  | 12-036F |  |  |  |  |  |  |  |  |  |  |  |  |  |  |  |  |  |  |  |  |  |
| 14312050c |  | Vend Fab Q1 Magnet Acceptance |  | 1175d | 2009-08-03 A | 2013-08-30 A | 14312050 FS-991d | 100% |  | 2009-08-03 | 2014-04-30 |  |  |  |  | PROCUREMENT>$50K 69 NO ESCALATION | 66,540.62 |  |  |  | 108588.4 | 66540.62 | FENKER H | 1 | 1 | P | HOWARD F |  | 12-012 |  |  | 10-067 | 10-069 | 11-026 |  | 0 | 66540.62 | 6654062 | 100 |  |  |  |  | 11-046 | 12-003 |  |  |  | Pat |  | 12-036 |  |  |  |  |  |  |  |  |  |  |  |  |  |  |  |  |  |  |  |  |  |
| 14312010a |  | Q1- Finalize Dsgn of Q1 " Final Phase" (Frozen and Reversed by Activity 14312011 per CR 09-041) |  | 1d | 2009-08-10 A | 2009-08-10 A | 9-090M FS+174d | 100% |  |  |  |  |  |  |  | TRAVEL | 1,436.89 |  |  |  | 0 | 1436.89 | FENKER H | 1 | 1 | H | HOWARD F |  |  | 08-048 | 09-022 |  |  |  |  |  |  |  |  |  | 4312 | 09-041 |  |  |  | APP |  | 08-016 |  |  |  |  |  |  |  |  |  |  |  |  |  |  |  |  |  |  |  |  |  |  |  |  |
| 14312010 |  | Q1- Finalize Dsgn of Q1 First Phase (Frozen and Reversed by Activity 14312011 per CR 09-041) |  | 0.25d | 2009-08-17 A | 2009-08-17 A | 9-090M FS+108d | 100% |  |  |  |  |  |  |  | TRAVEL | 2,227.93 |  |  |  | 0 | 2227.93 | FENKER H | 1 | 1 | H | HOWARD F |  |  | 08-048 | 09-022 |  |  |  |  |  |  |  |  |  | 4312 | 09-041 | 09-012 |  |  | APP |  | 08-016 |  |  |  |  |  |  |  |  |  |  |  |  |  |  |  |  |  |  |  |  |  |  |  |  |
| 14312000M |  | Q1- Award Contract for Q1 | milestone | 0d | 2009-09-01 A | 2009-09-01 A | 122311056, 9-090M | 100% |  | 2009-10-01 | 2009-10-01 |  |  | mandatory start 2009-03-16 |  |  |  |  |  |  |  | 0 | FENKER H | 1 | 1 | M | HOWARD F |  |  | 08-048 | 09-022 |  |  |  |  |  |  |  |  |  |  | 09-041 |  |  |  |  |  |  |  |  |  | 4 |  |  |  |  |  |  |  |  |  |  |  |  |  |  |  |  |  |  |  |  |
| 143128P2LOE |  | Q1- P-2 Contract Mngmnt for Q1 |  | 248d | 2009-10-01 A | 2010-09-30 A | 143128P1LOE | 100% |  |  |  |  |  |  |  | MECH DES [240 h]; TRAVEL; MECH ENG [400 h] | 50,383.02 | 37,197.6 | 100 | 100 | 0 | 50383.022139 | FENKER H | 1 | 1 | E | HOWARD F |  | 12-012 | 08-048 |  | 10-067 | 10-069 | 11-026 | 13-006F |  |  |  |  |  |  | 09-041 |  |  |  |  |  |  |  |  |  |  |  |  |  |  |  |  |  |  |  |  |  |  |  |  |  |  |  |  |  |  |
| 14312910LOE |  | Q1- FY10 Proj Mngmnt H-C upgrade |  | 248d | 2009-10-01 A | 2010-09-30 A | 14312909LOE | 100% |  |  |  |  |  |  |  | SCIENTIST [877.6 h] | 58,193.66 | 58,193.66 | 100 | 100 | 0 | 58193.656 | FENKER H | 1 | 1 | E | HOWARD F |  | 12-012 |  |  |  |  |  |  |  |  |  |  |  |  |  |  |  |  |  |  |  |  |  |  |  |  |  |  |  |  |  |  |  |  |  |  |  |  |  |  |  |  |  |  |  |
| 143128P3LOE |  | Q1- P-3 Contract Mngmnt for Q1 |  | 248d | 2010-10-01 A | 2011-09-30 A | 143128P2LOE | 100% |  |  |  |  |  |  |  | MECH ENG [360 h]; TRAVEL; MECH DES [80 h] | 37,267.09 | 28,196.4 | 100 | 100 | 0 | 37267.09 | FENKER H | 1 | 1 | E | HOWARD F |  | 12-012 | 08-048 |  | 10-067 | 10-069 | 11-026 | 13-006F |  |  |  |  |  |  |  |  |  |  |  |  |  |  |  |  |  | 8.46774193 | 91.53225806 |  |  |  |  |  |  |  |  |  |  |  |  |  |  |  |  |  |  |
| 14312911LOE |  | Q1- FY11 Proj Mngmnt H-C upgrade |  | 248d | 2010-10-01 A | 2011-09-30 A | 14312910LOE | 100% |  |  |  |  |  |  |  | SCIENTIST [877.6 h] | 60,054.17 | 60,054.17 | 100 | 100 | 0 | 60054.168 | FENKER H | 1 | 1 | E | HOWARD F |  | 12-012 |  |  |  |  |  |  |  |  |  |  |  |  |  |  |  |  |  |  |  |  |  |  |  | 8.46774193 | 91.53225806 |  |  |  |  |  |  |  |  |  |  |  |  |  |  |  |  |  |  |
| 14312005 |  | Q1- Final Dsgn Review |  | 11d | 2011-09-12 A | 2011-09-26 A | 14312040 FS-60d, 14312052M FS-70d | 100% |  |  |  |  |  |  |  | MECH DES [40 h]; TRAVEL; MECH ENG [40 h] | 9,120.54 | 4,585.2 |  |  | 0 | 9120.54 | FENKER H | 1 | 1 | H | HOWARD F |  | 12-012 | 08-048 | 09-022 | 10-067 | 10-069 | 11-026 |  |  |  |  |  |  |  | 09-041 |  | 11-046 | 12-003 |  |  |  |  |  |  |  |  |  |  |  |  |  |  |  |  |  |  |  |  |  |  |  |  |  |  |  |
| 143128P4LOE |  | Q1- P-4 Contract Mngmnt for Q1 |  | 247d | 2011-10-03 A | 2012-09-28 A | 143128P3LOE | 100% |  |  |  |  |  |  |  | TRAVEL; MECH ENG [360 h]; MECH DES [80 h] | 38,456.85 | 29,096.8 | 100 | 100 | 0 | 38456.85 | FENKER H | 1 | 1 | E | HOWARD F |  | 12-012 | 08-048 | 09-022 | 10-067 | 10-069 | 11-026 | 13-006F |  |  |  |  |  |  | 09-041 |  |  |  |  |  |  |  |  |  |  | 7.69230769 | 92.3076923 |  |  |  |  |  |  |  |  |  |  |  |  |  |  |  |  |  |  |
| 14312912LOE |  | Q1- FY12 Proj Mngmnt H-C upgrade |  | 247d | 2011-10-03 A | 2012-09-28 A | 14312911LOE | 100% |  |  |  |  |  |  |  | SCIENTIST [874 h] | 61,713.14 | 61,713.14 | 100 | 100 | 0 | 61713.14 | FENKER H | 1 | 1 | E | HOWARD F |  | 12-012 |  |  |  |  |  |  |  |  |  |  |  |  |  |  |  |  |  |  |  |  |  |  |  | 7.69230769 | 92.3076923 |  |  |  |  |  |  |  |  |  |  |  |  |  |  |  |  |  |  |
| 14312034 |  | Reverse Entry for activities 14312036,14312040,14312041 and 14312045 per CR12-003) |  | 1d | 2011-11-01 A | 2011-11-01 A | 9-120M | 100% |  |  |  |  |  |  |  | PROCUREMENT>$50K 69 NO ESCALATION | -380,059.4 |  |  |  |  |  | FENKER H | 1 | 1 | H | HOWARD F |  |  | 08-048 | 09-022 |  | 10-069 | 11-026 |  |  |  |  | 100 |  | 4312 | 09-041 | 09-012 | 11-046 | 12-003 | APP | 10-001A |  |  |  |  |  |  |  |  |  |  |  |  |  |  |  |  |  |  |  |  |  |  |  |  |  |
| 14312038 |  | Vend Fab Q1 Completion of Cold Mass Components (Revised Per CR12-003) |  | 10d | 2011-11-01 A | 2011-11-14 A | 9-120M FS+21d | 100% |  |  |  |  |  |  |  | PROCUREMENT>$50K 69 NO ESCALATION | 108,588.4 |  |  |  | 0 | 108588.4 | FENKER H | 1 | 1 | P | HOWARD F |  | 12-012 | 08-048 | 09-022 | 10-067 | 10-069 | 11-026 |  | 0 | 108588.4 | 10858840 | 100 |  | 4312 | 09-041 | 09-012 | 11-046 | 12-003 | APP | 10-001A | 08-016 |  |  | 12-036F |  |  |  | SC |  |  |  |  |  |  |  |  |  |  |  |  |  |  |  |  |  |
| 14312040a |  | Vend Fab Q1 Completion of Cold Mass Assembly (Revised Per CR12-003) |  | 390d | 2011-11-01 A | 2013-08-30 A | 14312038 FS-37d | 100% |  | 2011-11-01 | 2013-05-31 |  |  |  |  | PROCUREMENT>$50K 69 NO ESCALATION | 54,294.2 |  |  |  | 21717.68 | 54294.2 | FENKER H | 1 | 1 | S | HOWARD F |  | 12-012 | 08-048 | 09-022 | 10-067 | 10-069 | 11-026 |  | 0 | 54294.2 | 5429420 | 100 |  | 4312 | 09-041 | 09-012 | 11-046 | 12-003 | APP | 10-001A | 08-016 |  |  | 12-036F |  |  |  | SC | ST | MP |  |  |  |  |  |  |  |  |  |  |  |  |  |  |  |
| 14312040d |  | Vend Fab Q1 Completion of Cold Mass Testing |  | 390d | 2011-11-01 A | 2013-08-30 A | 14312040a FS-155d | 100% |  | 2011-11-01 | 2013-05-31 |  |  |  |  | PROCUREMENT>$50K 69 NO ESCALATION | 54,294.2 |  |  |  | 54294.2 | 54294.2 | FENKER H | 1 | 1 | P | HOWARD F |  | 12-012 | 08-048 | 09-022 | 10-067 | 10-069 | 11-026 |  | 0 | 54294.2 | 5429420 | 100 |  | 4312 | 09-041 | 09-012 | 11-046 | 12-003 | APP | 10-001A | 08-016 |  |  | 12-036F |  |  |  | SC |  |  |  |  |  |  |  |  |  |  |  |  |  |  |  |  |  |
| 14312041a |  | Vend Fab Q1 Warm Testing Complete (Revised Per CR12-003) |  | 390d | 2011-11-01 A | 2013-08-30 A | 14312040d FS-226d | 100% |  | 2011-11-01 | 2013-05-31 |  |  |  |  | PROCUREMENT>$50K 69 NO ESCALATION | 54,294.2 |  |  |  | 54294.2 | 54294.2 | FENKER H | 1 | 1 | P | HOWARD F |  | 12-012 |  |  | 10-067 | 10-069 | 11-026 |  | 0 | 54294.2 | 5429420 | 100 |  | 4312 |  |  | 11-046 | 12-003 | APP |  |  |  |  | 12-036F |  |  |  | SC |  |  |  |  |  |  |  |  |  |  |  |  |  |  |  |  |  |
| 14312045a |  | Vend Fab Q1 Completion of Cryostat Components (Revised Per CR12-003) |  | 390d | 2011-11-01 A | 2013-06-17 A | 14312041a FS-162d | 100% |  | 2011-11-01 | 2013-05-31 |  |  |  |  | PROCUREMENT>$50K 69 NO ESCALATION | 108,588.4 |  |  |  | 0 | 108588.4 | FENKER H | 1 | 1 | S | HOWARD F |  | 12-012 | 08-048 | 09-022 | 10-067 | 10-069 | 11-026 |  | 0 | 108588.4 | 10858840 | 100 |  | 4312 | 09-041 |  | 11-046 | 12-003 | APP | 10-001A |  |  |  | 12-036F |  |  |  | SC | ST | MP |  |  |  |  |  |  |  |  |  |  |  |  |  |  |  |
| 143128P5LOE |  | Q1- P-5 Contract Mngmnt for Q1 |  | 248d | 2012-10-01 A | 2013-08-30 A | 143128P4LOE | 100% |  | 2012-10-01 | 2013-09-30 |  |  |  |  | TRAVEL; MECH ENG [330.97 h]; MECH DES [73.55 h] | 39,987.98 | 27,605.18 | 100 | 100 | 7184.11848 | 38989.370289 | FENKER H | 1 | 1 | E | HOWARD F |  | 12-012 | 08-048 | 09-022 | 10-067 | 10-069 | 11-026 | 13-006F |  |  |  |  |  |  | 09-041 |  |  |  |  |  |  |  |  |  |  | 8.06451612 | 91.93548387 |  |  |  | 143128P5LOE |  |  |  |  |  |  |  |  |  |  |  |  |  |  |
| 14312913LOE |  | Q1- FY13 Proj Mngmnt H-C upgrade |  | 248d | 2012-10-01 A | 2013-08-30 A | 14312912LOE | 100% |  | 2012-10-01 | 2013-09-30 |  |  |  |  | SCIENTIST [809.03 h] | 58,945.93 | 59,021.61 | 100 | 100 | 10861.38592 | 58945.9258 | FENKER H | 1 | 1 | E | HOWARD F |  | 12-012 |  |  |  | 10-069 |  |  |  |  |  |  |  |  |  |  |  |  |  |  |  |  |  |  |  | 8.06451612 | 91.93548387 |  |  |  | 14312913LOE |  |  |  |  |  |  |  |  |  |  |  |  |  |  |
| 143128P5TLOE |  | Q1- P-5 Extra Travel for Q1 Contract Mgmt |  | 189d | 2013-01-02 A | 2013-08-30 A | 143128P5LOE FS-189d | 100% |  | 2013-02-01 | 2013-10-29 |  |  |  |  | TRAVEL | 5,901.59 |  | 100 | 100 | 1466.52 | 5901.59 | FENKER H | 1 | 1 | E | HOWARD F |  |  |  |  |  |  |  | 13-006 |  |  |  |  |  |  |  |  |  |  |  |  |  |  |  |  |  | 10.58201058 | 89.41798941 |  |  |  |  |  |  |  |  |  |  |  |  |  |  |  |  |  |  |
| 143128PC13LOE |  | Q1- Contract Oversight Consultant FY13 |  | 189d | 2013-01-02 A | 2013-08-30 A | 9-130M FS+59d | 100% |  | 2013-02-01 | 2013-10-29 |  |  |  |  | PLABOR | 8,047.62 |  | 100 | 100 | 1999.8 | 8047.62 | FENKER H | 1 | 1 | E | HOWARD F |  |  |  |  |  |  |  | 13-006 |  |  |  |  |  |  |  |  |  |  |  |  |  |  |  |  |  | 10.58201058 | 89.41798941 |  |  |  |  |  |  |  |  |  |  |  |  |  |  |  |  |  |  |
| 14312950 |  | Re-Baseline Actuals Adjustment |  | 1d | 2013-08-30 A | 2013-08-30 A |  | 100% |  | 2013-09-03 | 2013-09-03 |  |  |  |  | PROCUREMENT>$50K 69 NO ESCALATION | -220,221.78 |  |  |  |  |  |  |  |  |  |  |  |  |  |  |  |  |  |  |  |  |  | 100 |  |  |  |  |  |  |  |  |  |  |  |  |  |  |  |  |  |  |  | ADJ |  |  |  |  |  |  |  |  |  |  |  |  |  |
| 24312040d |  | Vend Fab Q1 Completion of Cold Mass Testing |  | 98d | 2013-09-03 A | 2014-01-31 | 9-130M FS+228d |  | 55d |  |  | 567d | 95d |  | 8/5 M-F w/JLAB Holidays ReBaseline | PROCUREMENT>$50K 69 NO ESCALATION | 54,294.2 |  |  |  |  | 0 | FENKER H | 1 | 1 | P | HOWARD F |  | 12-012 | 08-048 | 09-022 | 10-067 | 10-069 | 11-026 | 13-006F | 54294.2 | 0 | 0 | 100 |  | 4312 | 09-041 | 09-012 | 11-046 | 12-003 | APP | 10-001A | 08-016 |  |  | 12-036F |  |  |  | SC |  |  |  |  | OPEN OBLIGATION | 24312040d | Y | OB | YES | 13-015 | PR | OB |  |  |  |  |  |
| 24312041a |  | Vend Fab Q1 Warm Testing Complete |  | 98d | 2013-09-03 A | 2014-01-31 | 24312040d FS-150d |  | 55d |  |  | 472d | 105d |  | 8/5 M-F w/JLAB Holidays ReBaseline | PROCUREMENT>$50K 69 NO ESCALATION | 54,294.2 |  |  |  |  | 0 | FENKER H | 1 | 1 | P | HOWARD F |  | 12-012 |  |  | 10-067 | 10-069 | 11-026 | 13-006F | 54294.2 | 0 | 0 | 100 |  | 4312 |  |  | 11-046 | 12-003 | APP |  |  |  |  | 12-036F |  |  |  | SC |  |  |  |  | OPEN OBLIGATION | 24312041a |  | OB | YES | 13-015 | PR | OB |  |  |  |  |  |
| 24312046 |  | Vend Fab Q1 Completion of Cryostat Assembly |  | 161d | 2013-09-03 A | 2014-05-30 | 9-130M FS+228d |  | 139d | 2013-09-03 | 2014-04-30 | 126d | 49d |  | 8/5 M-F w/JLAB Holidays ReBaseline | PROCUREMENT>$50K 69 NO ESCALATION | 54,294.2 |  |  |  |  | 0 | FENKER H | 1 | 1 | P | HOWARD F |  | 12-012 |  |  | 10-067 | 10-069 | 11-026 | 13-006 | 54294.2 | 0 | 0 | 100 |  |  | 09-041 |  | 11-046 | 12-003 |  | 10-001A |  |  | 10-063 | 12-036F |  |  |  | SC |  |  |  |  | OPEN OBLIGATION | 24312046 |  | OB | YES | 13-015 | PR | OB |  |  |  |  |  |
| 24312047 |  | Vend Fab Q1 Completion of Magnet Assembly |  | 182d | 2013-09-03 A | 2014-05-30 | 24312046 FS-260d |  | 139d |  |  | 108d | 31d |  | 8/5 M-F w/JLAB Holidays ReBaseline | PROCUREMENT>$50K 69 NO ESCALATION | 54,294.2 |  |  |  |  | 0 | FENKER H | 1 | 1 | P | HOWARD F |  | 12-012 |  |  | 10-067 | 10-069 | 11-026 | 13-006 | 54294.2 | 0 | 0 | 100 |  |  | 09-041 |  | 11-046 | 12-003 |  | 10-001A |  |  |  | 12-036F |  |  |  | SC |  |  |  |  | OPEN OBLIGATION | 24312047 |  | OB | YES | 13-015 | PR | OB |  |  |  |  |  |
| 24312048 |  | Vend Fab Q1 Completion of Factory Tests by Vendor |  | 203d | 2013-09-03 A | 2014-06-30 | 24312047 FS-280d |  | 160d |  |  | 87d | 0d |  | 8/5 M-F w/JLAB Holidays ReBaseline | PROCUREMENT>$50K 69 NO ESCALATION | 54,294.2 |  |  |  |  | 0 | FENKER H | 1 | 1 | P | HOWARD F |  | 12-012 |  |  | 10-067 | 10-069 | 11-026 | 13-006 | 54294.2 | 0 | 0 | 100 |  |  | 09-041 |  | 11-046 | 12-003 |  | 10-001A |  |  | 10-063 | 12-036F |  |  |  | SC |  |  |  |  | OPEN OBLIGATION | 24312048 |  | OB |  | 13-015 | PR | OB |  |  |  |  |  |
| 24312050 |  | Vend Fab Q1 Magnet System Delivery |  | 203d | 2013-09-03 A | 2014-07-15 | 24312048 FS-300d |  | 170d | 2013-09-03 | 2014-06-30 | 77d | 0d |  | 8/5 M-F w/JLAB Holidays ReBaseline | PROCUREMENT>$50K 69 NO ESCALATION | 54,294.2 |  |  |  |  | 0 | FENKER H | 1 | 1 | P | HOWARD F |  | 12-012 | 08-048 | 09-022 | 10-067 | 10-069 | 11-026 | 13-006 | 54294.2 | 0 | 0 | 100 |  |  | 09-041 | 09-012 | 11-046 | 12-003 |  | 10-001A |  |  |  | 12-036F |  |  |  | SC |  |  |  |  | OPEN OBLIGATION | 24312050 | Y | OB | YES | 13-015 | PR | OB |  |  |  |  |  |
| 24312050c |  | Vend Fab Q1 Magnet Acceptance |  | 246d | 2013-09-03 A | 2014-09-30 | 24312050 FS-250d |  | 224d | 2013-09-03 | 2014-08-29 | 250d | 0d |  | 8/5 M-F w/JLAB Holidays ReBaseline | PROCUREMENT>$50K 69 NO ESCALATION | 108,588.4 |  |  |  |  | 0 | FENKER H | 1 | 1 | P | HOWARD F |  | 12-012 |  |  | 10-067 | 10-069 | 11-026 | 13-006 | 108588.4 | 0 | 0 | 100 |  |  |  |  | 11-046 | 12-003 |  |  |  |  |  | 12-036 |  |  |  |  |  |  |  |  | OPEN OBLIGATION | 24312050c |  | OB | YES | 13-015 | PR | OB |  |  |  |  |  |
| 24312060 |  | Q1 Schedule Acceleration Incentives |  | 203d | 2013-09-03 A | 2014-08-01 | 9-130M FS+228d |  | 183d | 2013-09-03 | 2014-06-30 | 344d | 35d |  | 8/5 M-F w/JLAB Holidays ReBaseline | PROCUREMENT<$50K 60 NO ESCALATION FY14 | 45,000 |  |  |  |  | 0 | FENKER H | 1 | 1 | D | HOWARD F |  | 12-012 |  |  | 10-067 | 10-069 | 11-026 | 13-006 | 45000 | 0 | 0 | 100 |  |  |  |  |  | 12-003 |  |  |  |  |  | 12-036 |  |  |  |  |  |  |  |  |  | 24312060 |  | EJ |  | 13-015 | PR | OB | 12-054 |  |  |  |  |
| 243128P5LOE |  | Q1- P-5 Contract Mngmnt for Q1 |  | 20d | 2013-09-03 A | 2013-09-30 A | 9-130M FS+228d | 100% |  | 2013-10-01 | 2013-10-28 |  |  |  | 8/5 M-F w/JLAB Holidays ReBaseline | MECH ENG [29.03 h]; TRAVEL; MECH DES [6.45 h] | 3,496.67 | 2,421.23 |  |  |  | 0 | FENKER H | 1 | 1 | E | HOWARD F |  | 12-012 | 08-048 | 09-022 | 10-067 | 10-069 | 11-026 | 13-006F |  |  |  |  |  |  | 09-041 |  |  |  |  |  |  |  |  |  |  |  |  |  |  |  |  |  | OPEN OBLIGATION | 243128P5LOE |  |  |  | 13-015 | PR |  |  | 3419.350764 | PE | PE |  |
| 243128P5TLOE |  | Q1- P-5 Extra Travel for Q1 Contract Mgmt |  | 20d | 2013-09-03 A | 2013-09-30 A | 243128P5LOE FS-20d | 100% |  | 2013-10-01 | 2013-10-28 |  |  |  | 8/5 M-F w/JLAB Holidays ReBaseline | TRAVEL | 698.26 |  |  |  |  | 0 | FENKER H | 1 | 1 | E | HOWARD F |  |  |  |  |  |  |  | 13-006 |  |  |  |  |  |  |  |  |  |  |  |  |  |  |  |  |  |  |  |  |  |  |  |  |  | 243128P5TLOE |  |  |  | 13-015 | PR |  |  | 698.26 | PE | PE |  |
| 243128PC13LOE |  | Q1- Contract Oversight Consultant |  | 98d | 2013-09-03 A | 2014-01-31 | 9-130M FS+228d | 44% | 55d |  |  | 784d | 0d |  | 8/5 M-F w/JLAB Holidays ReBaseline | PROCUREMENT<$50K 60 NO ESCALATION FY14 | 4,000 |  | 100 | 100 |  | 938.8 | FENKER H | 1 | 1 | E | HOWARD F |  |  |  |  |  |  |  | 13-006 | 2244.8 | 1755.2 | 175520 | 100 |  |  |  |  |  |  |  |  |  |  |  |  |  | 56.12244897 | 43.87755102 |  |  |  |  |  |  | 243128PC13LOE |  | OB |  | 13-015 | PR | OB |  | 816.4 |  |  |  |
| 24312913LOE |  | Q1- FY13 Proj Mngmnt H-C upgrade |  | 20d | 2013-09-03 A | 2013-09-30 A | 9-130M FS+228d | 100% |  | 2013-10-01 | 2013-10-28 |  |  |  | 8/5 M-F w/JLAB Holidays ReBaseline | SCIENTIST [70.95 h] | 5,334.02 | 5,169.42 |  |  |  | 0 | FENKER H | 1 | 1 | E | HOWARD F |  | 12-012 |  |  |  | 10-069 |  | 13-006F |  |  |  |  |  |  |  |  |  |  |  |  |  |  |  |  |  |  |  |  |  |  |  |  | OPEN OBLIGATION | 24312913LOE |  |  |  | 13-015 | PR |  |  | 5169.417 | PE |  |  |
| 243128P6LOE |  | Q1- P-6 Contract Mngmnt for Q1 |  | 247d | 2013-10-01 A | 2014-09-30 | 243128P5TLOE | 9% | 224d | 2013-11-01 | 2014-10-31 | 249d | 0d |  | 8/5 M-F w/JLAB Holidays ReBaseline | TRAVEL; MECH ENG [440 h] | 53,492.8 | 3,059.35 | 100 | 100 |  | 4980.17968 | FENKER H | 1 | 1 | E | HOWARD F |  |  |  |  |  |  |  | 13-006 |  |  |  |  |  |  |  |  |  |  |  |  |  |  |  |  |  | 90.6882591 | 9.31174089 |  |  |  |  |  |  | 243128P6LOE |  |  |  | 13-015 | PR |  |  |  | PE | PE | 14-001 |
| 24312914LOE |  | Q1- FY14 Proj Mngmnt H-C upgrade |  | 247d | 2013-10-01 A | 2014-09-30 | 24312913LOE | 9% | 224d | 2013-11-01 | 2014-10-31 | 439d | 0d |  | 8/5 M-F w/JLAB Holidays ReBaseline | SCIENTIST [880 h] | 66,158.4 | 6,160.5 | 100 | 100 |  | 6159.34704 | FENKER H | 1 | 1 | E | HOWARD F |  |  |  |  |  |  |  | 13-006 |  |  |  |  |  |  |  |  |  |  |  |  |  |  |  |  |  | 90.6882591 | 9.31174089 |  |  |  |  |  |  | 24312914LOE |  |  |  | 13-015 | PR |  |  |  | PE |  | 14-001 |
| 14312052M |  | Factory Low Current Mag Test of Q1 Complete | milestone | 0d | 2013-11-01 | 2013-11-01 | 14312041, 14312048, 14312040 |  |  |  |  | 967d | 70d |  |  |  |  |  |  |  |  | 0 | FENKER H | 1 | 1 | M | HOWARD F |  | 12-012 |  |  | 10-067 | 10-069 | 11-026 |  |  |  |  |  |  |  | 09-041 |  | 11-046 | 12-003 |  |  |  |  |  |  |  |  |  |  |  |  | 14312052M |  |  |  |  |  |  |  |  |  |  |  |  |  |  |
| 243128PC13LOE5 |  | Q1- Contract Oversight Consultant |  | 127d | 2014-02-03 | 2014-07-31 | 243128PC13LOE |  |  |  |  | 784d | 846d |  | 8/5 M-F w/JLAB Holidays ReBaseline | PROCUREMENT<$50K 60 | 8,255.2 |  | 100 | 100 |  | 0 | FENKER H | 1 | 1 | E | HOWARD F |  |  |  |  |  |  |  | 13-006 | 8255.2 | 0 | 0 | 100 |  |  |  |  |  |  |  |  |  |  |  |  |  | 100 | 0 |  |  |  |  |  |  | 243128PC13LOE |  | OB |  | 13-015 | PR |  |  |  |  |  | 14-001 |
| 24312052M |  | Factory Low Current Mag Test of Q1 Complete | milestone | 0d | 2014-06-30 | 2014-06-30 | 24312041a, 24312048 |  |  |  |  | 367d | 58d |  | 8/5 M-F w/JLAB Holidays ReBaseline |  |  |  |  |  |  | 0 | FENKER H | 1 | 1 | M | HOWARD F |  | 12-012 |  |  | 10-067 | 10-069 | 11-026 | 13-006F |  |  |  |  |  |  | 09-041 |  | 11-046 | 12-003 |  |  |  |  |  |  |  |  |  |  |  |  |  |  |  | 24312052M |  |  |  | 13-015 | PR |  |  |  |  |  |  |
| 24312053M |  | Q1 Delivered to JLab | milestone | 0d | 2014-07-15 | 2014-07-15 | 24312050, 24312046 FS-18d, 24312048, 24312047 |  |  |  |  | 77d | 0d |  | 8/5 M-F w/JLAB Holidays ReBaseline |  |  |  |  |  |  | 0 | FENKER H | 1 | 1 | M | HOWARD F |  | 12-012 |  |  | 10-067 | 10-069 | 11-026 | 13-006 |  |  |  |  |  |  | 09-041 |  | 11-046 | 12-003 |  |  |  |  |  | 12-036 |  |  |  |  |  |  |  |  |  | 24312053M |  |  |  | 13-015 | PR |  |  |  |  |  |  |
| 24312050d |  | Q1 Drawing Validation |  | 100d | 2014-07-16 | 2014-12-05 | 24312050, 24312053M |  |  |  |  | 258d |  |  | 8/5 M-F w/JLAB Holidays ReBaseline | MECH DES [480 h] | 24,624 |  |  |  |  | 0 | FENKER H | 1 | 1 | S | HOWARD F |  |  | 08-048 | 09-022 |  | 10-069 | 11-026 | 13-006 |  |  |  |  |  |  | 09-041 | 09-012 |  | 12-003 |  | 10-001A |  | Pat |  | 12-036 |  |  |  |  | ST |  |  |  |  | 24312050d |  |  |  | 13-015 | PR |  |  |  | PE |  | 14-001 |
| 24312051M |  | Q1 Acceptance Test Complete | milestone | 0d | 2014-09-22 | 2014-09-22 | 28231005 |  |  |  |  | 275d | 0d |  | 8/5 M-F w/JLAB Holidays ReBaseline |  |  |  |  |  |  | 0 | FENKER H | 1 | 1 | M | HOWARD F |  | 12-012 | 08-048 | 09-022 | 10-067 | 10-069 | 11-026 | 13-006 |  |  |  |  |  |  | 09-041 | 09-012 | 11-046 | 12-003 |  |  |  |  |  | 12-036 |  |  |  |  |  |  |  |  |  | 24312051M |  |  |  | 13-015 | PR |  | 12-054 |  |  |  |  |
| 24312055 |  | Pay Profit on Q1 |  | 1d | 2014-09-23 | 2014-09-23 | 24312050, 24312060, 24312051M, 24312052M |  |  |  |  | 309d |  |  | 8/5 M-F w/JLAB Holidays ReBaseline |  |  |  |  |  |  | 0 | FENKER H | 1 | 1 | Z | HOWARD F |  | 12-012 |  |  | 10-067 | 10-069 | 11-026 | 13-006 |  |  |  |  |  |  |  |  |  | 12-003 |  |  |  |  |  | 12-036 |  |  |  |  |  |  |  |  | NO RESOURCES | 24312055 |  |  |  | 13-015 | PR |  | 12-054 |  |  |  |  |
| 243128P6LOE5 |  | Q1- P-7 Contract Mngmnt for Q1 |  | 55d | 2014-10-01 | 2014-12-18 | 243128P5TLOE, 243128P6LOE |  |  |  |  | 249d |  |  | 8/5 M-F w/JLAB Holidays ReBaseline | TRAVEL; MECH ENG [110 h] | 8,213.7 |  | 100 | 100 |  | 0 | FENKER H | 1 | 1 | E | HOWARD F |  |  |  |  |  |  |  | 13-006 |  |  |  |  |  |  |  |  |  |  |  |  |  |  |  |  |  | 100 | 0 |  |  |  |  |  |  | 243128P6LOE5 |  |  |  | 13-015 | PR |  |  |  | PE | PE | 14-001 |
| 24312915LOE |  | Q1- FY15 Proj Mngmnt H-C upgrade |  | 246d | 2014-10-01 | 2015-09-30 | 24312914LOE |  |  |  |  | 439d | 0d |  | 8/5 M-F w/JLAB Holidays ReBaseline | SCIENTIST [880 h] | 66,158.4 |  | 100 | 100 |  | 0 | FENKER H | 1 | 1 | E | HOWARD F |  |  |  |  |  |  |  | 13-006 |  |  |  |  |  |  |  |  |  |  |  |  |  |  |  |  |  | 100 | 0 |  |  |  |  |  |  | 24312915LOE |  |  |  | 13-015 | PR |  |  |  | PE |  | 14-001 |
| 24312915LOE5 |  | Q1- FY16 Proj Mngmnt H-C upgrade |  | 57d | 2015-10-01 | 2015-12-22 | 24312914LOE, 24312915LOE |  |  |  |  | 439d | 501d |  | 8/5 M-F w/JLAB Holidays ReBaseline | SCIENTIST [120 h] | 9,021.6 |  | 100 | 100 |  | 0 | FENKER H | 1 | 1 | E | HOWARD F |  |  |  |  |  |  |  | 13-006 |  |  |  |  |  |  |  |  |  |  |  |  |  |  |  |  |  | 100 | 0 |  |  |  |  |  |  | 24312915LOE5 |  |  |  | 13-015 | PR |  |  |  | PE |  | 14-001 |

Notes:
- 14312015: Corrective Actions: 07 Mar 2007, Added This Activity to / Match Fy08-15 Master Schedule. PMC
- 14312040a: Steps: Acceptance of JLab Cryo Control Reservoir (done); Wind Coil 1 (done); Wind Coil 2 (done); Wind Coil 3 (done); Coil Winding Complete (done); Cold Mass Assembly Complete (done)
- 14312045a: Steps: Vessel Components Materials Traceability (C-3) (done); Vessel Materials Certifications (C-2) (done); Weld qualification (C-5) (done); Welder qualifications (C-6) (done); 100% Drawing package (D-15) (done); Cryostat Components Complete (F-11) (done)
- 24312050d: Steps: 1st 25% of vendor-supplied drawings checked; 2nd 25% of vendor-supplied drawings checked; 3rd 25% of vendor-supplied drawings checked; 4th 25% of vendor-supplied drawings checked

| ID | WBS | Activity | Type | Duration | Start | Finish | Predecessors | Complete | Remaining | Planned start | Planned finish | Total float | Free float | Constraint | Calendar | Resources | Cost | Actual cost | LOE Divider | LOE Multiplier | Calculated Remaining Total Cost | MONTHLY EV COST | RESP - Responsibility | STRT%COMP for CM EVM | FNSH%COMP for CM EVM | CR 07-034 | EVMS Reporting Codes | CAM RESPONSIBLE | CR 08-048 | CR 09-022 | CR 10-008 | CR 10-069 | CR 11-017 | CR 11-026 | CR 12-036 | LOE % Pre Calc | LOE % | Milestone Level | Remaining Material Cost Based on % Compl | Claimed Material Cost Based on % Complet | Initial Claimed Material Calc | Claimed Material Divider | 12 GEV MAJOR PROCUREMENT CATAGORY | CR 12-012 | CR 09-012 | Activities with Steps | Phil Dev | Specification | ReBaseline Actuals Adjustment | BOE NOTES | Original Activity ID Rebaseline | SC Magnet Dates | CR 13-006 | BOE Procurement | BOE Adder | CR 13-015 | Post Rebaseline | Obligated Prior to Rebaseline | PRIOR MONTH EV COST | BOE Labor | BOE Expenses | CR 14-001 | Pat's Code |
| --- | --- | --- | --- | --- | --- | --- | --- | --- | --- | --- | --- | --- | --- | --- | --- | --- | --- | --- | --- | --- | --- | --- | --- | --- | --- | --- | --- | --- | --- | --- | --- | --- | --- | --- | --- | --- | --- | --- | --- | --- | --- | --- | --- | --- | --- | --- | --- | --- | --- | --- | --- | --- | --- | --- | --- | --- | --- | --- | --- | --- | --- | --- | --- |
|  | 3 | **1.4.3.1.3 Q2-3 QUADRUPOLE** |  |  | 2009-12-14 | 2016-02-03 |  |  |  |  |  |  |  |  |  |  |  |  |  |  |  |  |  |  |  |  |  |  |  |  |  |  |  |  |  |  |  |  |  |  |  |  |  |  |  |  |  |  |  |  |  |  |  |  |  |  |  |  |  |  |  |  |  |
| 14313P1LOE |  | Q2&3- P-1 Contract Mngmnt for Q2-3 |  | 198d | 2009-12-14 A | 2010-09-30 A | 9-100M FS+50d | 100% |  |  |  |  |  |  |  | MECH DES [120 h]; MECH ENG [200 h]; TRAVEL | 24,092.73 | 18,598.8 | 100 | 100 | 0 | 24092.728471 | FENKER H | 1 | 1 | 07-034 | E | HOWARD F | 08-048 | 09-022 | 10-008 | 10-069 | 11-017 | 11-026 | 12-036F |  |  |  |  |  |  |  |  |  |  |  |  |  |  |  |  |  |  |  |  |  |  |  |  |  |  |  |  |
| 14313P2LOE |  | Q2&3- P-2 Contract Mngmnt for Q2-3 |  | 248d | 2010-10-01 A | 2011-09-30 A | 14313P1LOE | 100% |  |  |  |  |  |  |  | TRAVEL; MECH ENG [440 h]; MECH DES [80 h] | 44,970.77 | 33,632.4 | 100 | 100 | 0 | 44970.77 | FENKER H | 1 | 1 | 07-034 | E | HOWARD F | 08-048 | 09-022 |  | 10-069 | 11-017 | 11-026 | 12-036F | 8.46774193 | 91.53225806 |  |  |  |  |  |  |  |  |  |  |  |  |  |  |  |  |  |  |  |  |  |  |  |  |  |  |
| 14313000M |  | Q2&3- Award Contract for SHMS Q2/Q3 quadrupoles | milestone | 0d | 2010-12-01 A | 2010-12-01 A | 9-090M FS+60d, 122312070 | 100% |  | 2011-01-04 | 2011-01-04 |  |  | mandatory start 2010-10-18 |  |  |  |  |  |  |  | 0 | FENKER H | 1 | 1 |  | M | HOWARD F | 08-048 |  | 10-008 |  |  |  |  |  |  | 4 |  |  |  |  |  |  |  |  |  |  |  |  |  |  |  |  |  |  |  |  |  |  |  |  |  |
| 14313002 |  | Q2&3- Contractor Expenses |  | 17d | 2010-12-01 A | 2010-12-30 A | 14313000M | 100% |  |  |  |  |  |  |  | PROCUREMENT>$50K 69 | 75,967.04 |  |  |  | 0 | 75967.04 | FENKER H | 1 | 1 | 07-034 | H | HOWARD F | 08-048 |  | 10-008 | 10-069 | 11-017 | 11-026 | 12-036F |  |  |  | 0 | 75967.04 | 7596704 | 100 | 4313 | 12-012 |  |  |  |  |  |  |  |  |  |  |  |  |  |  |  |  |  |  |  |
| 14313005 |  | Q2&3- Finalize Dsgn for Q2/Q3 Mags Original Expenses |  | 7d | 2010-12-01 A | 2010-12-09 A | 14313000M, 14313002, 14313002a FS-40d | 100% |  |  |  |  |  |  |  | TRAVEL | 596.76 |  |  |  | 0 | 596.76 | FENKER H | 1 | 1 | 07-034 | H | HOWARD F | 08-048 |  | 10-008 | 10-069 | 11-017 | 11-026 | 12-036F |  |  |  |  |  |  |  | 4313 | 12-012 | 09-012 |  |  |  |  |  |  |  |  |  |  |  |  |  |  |  |  |  |  |
| 14313006 |  | Vend Fab Q2&3 Peg Point #1 Intermediate Design Review |  | 592d | 2010-12-07 A | 2013-07-15 A | 14313000M | 100% |  | 2010-12-07 | 2013-04-30 |  |  |  |  | PROCUREMENT<$50K 60 NO ESCALATION; PROCUREMENT>$50K 69 NO ESCALATION | 158,700 |  |  |  | 0 | 158700 | FENKER H | 1 | 1 |  | P | HOWARD F |  |  |  |  | 11-017 | 11-026 | 12-036F |  |  |  | 0 | 158700 | 15870000 | 100 | 4313 | 12-012 |  |  |  |  |  |  |  |  |  |  |  |  |  |  |  |  |  |  |  |
| 14313010 |  | Vend Fab Q2&3 Peg Point #2a Final Design Review |  | 634d | 2010-12-07 A | 2013-08-30 A | 14313020 FS-195d, 14313006 FS-195d, 14315016 FS-195d | 100% |  | 2010-12-07 | 2013-06-28 |  |  |  |  | PROCUREMENT>$50K 69 NO ESCALATION | 441,300 |  |  |  | 441300 | 441300 | FENKER H | 1 | 1 | 07-034 | S | HOWARD F | 08-048 |  | 10-008 | 10-069 | 11-017 | 11-026 | 12-036F |  |  |  | 0 | 441300 | 44130000 | 100 | 4313 | 12-012 |  | ST | MP |  |  |  |  |  |  |  |  |  |  |  |  |  |  |  |  |
| 14313002a |  | Reverse Entry per CR 11-017 |  | 3d | 2010-12-21 A | 2010-12-30 A | 14313000M FS+30d | 100% |  |  |  |  |  |  |  | PROCUREMENT>$50K 69 | -75,967.04 |  |  |  |  |  | FENKER H | 1 | 1 | 07-034 | H | HOWARD F | 08-048 |  | 10-008 | 10-069 | 11-017 | 11-026 | 12-036F |  |  |  |  |  |  | 100 | 4313 | 12-012 |  |  |  |  |  |  |  |  |  |  |  |  |  |  |  |  |  |  |  |
| 14313015 |  | Vend Fab Q2&3 Peg Point #2b Final Design Review |  | 601d | 2011-02-01 A | 2013-08-30 A | 14313005, 14313010 FS-230d | 100% |  | 2011-02-01 | 2013-06-28 |  |  |  |  | PROCUREMENT<$50K 60 NO ESCALATION | 48,400 |  |  |  | 48400 | 48400 | FENKER H | 1 | 1 | 07-034 | S | HOWARD F | 08-048 |  | 10-008 | 10-069 | 11-017 | 11-026 | 12-036F |  |  |  | 0 | 48400 | 4840000 | 100 | 4313 | 12-012 | 09-012 | ST | MP |  |  |  |  |  |  |  |  |  |  |  |  |  |  |  |  |
| 14313017 |  | Vend Fab Q2&3 Peg Point #3 Cryostat Component Complete |  | 688d | 2011-02-01 A | 2013-08-30 A | 14315029 FS-265d, 14313030 FS-230d, 14313015 FS-230d | 100% |  | 2011-02-01 | 2013-10-31 |  |  |  |  | PROCUREMENT<$50K 60 NO ESCALATION; PROCUREMENT>$50K 69 NO ESCALATION | 432,250 |  |  |  | 432250 | 432250 | FENKER H | 1 | 1 | 07-034 | P | HOWARD F | 08-048 | 09-022 | 10-008 | 10-069 | 11-017 | 11-026 | 12-036F |  |  |  | 0 | 432250 | 43225000 | 100 | 4313 | 12-012 | 09-012 |  |  |  |  |  |  |  |  |  |  |  |  |  |  |  |  |  |  |
| 14313018 |  | Vend Fab Q2&3 Peg Point #4a Cold Mass Fiducialitzation |  | 954d | 2011-02-01 A | 2013-08-30 A | 14313017 FS-355d, 14315027 | 100% |  | 2011-02-01 | 2014-11-26 |  |  |  |  | PROCUREMENT>$50K 69 NO ESCALATION | 319,350 |  |  |  | 319350 | 319350 | FENKER H | 1 | 1 | 07-034 | P | HOWARD F | 08-048 | 09-022 | 10-008 | 10-069 | 11-017 | 11-026 | 12-036F |  |  |  | 0 | 319350 | 31935000 | 100 | 4313 | 12-012 |  |  |  |  |  |  |  |  |  |  |  |  |  |  |  |  |  |  |  |
| 14313020 |  | PDR/IDR Site Inspection |  | 433d | 2011-08-01 A | 2013-07-15 A | 14313006 FS-124d | 100% |  | 2011-08-01 | 2013-04-30 |  |  |  |  | MECH ENG [40 h]; TRAVEL | 13,616.97 | 2,832.77 |  |  | 0 | 13509.61 | FENKER H | 1 | 1 | 07-034 | H | HOWARD F | 08-048 |  | 10-008 | 10-069 | 11-017 | 11-026 | 12-036F |  |  |  |  |  |  |  |  | 12-012 |  |  |  | 14313020 |  |  |  |  |  |  |  |  |  |  |  |  |  |  |  |
| 14313P3LOE |  | Q2&3- P-3 Contract Mngmnt for Q2-3 |  | 247d | 2011-10-03 A | 2012-09-28 A | 14313P2LOE | 100% |  |  |  |  |  |  |  | MECH DES [80 h]; MECH ENG [440 h]; TRAVEL | 41,726.45 | 34,706.4 | 100 | 100 | 0 | 41726.45 | FENKER H | 1 | 1 | 07-034 | E | HOWARD F | 08-048 | 09-022 |  | 10-069 | 11-017 | 11-026 | 12-036F | 7.69230769 | 92.3076923 |  |  |  |  |  |  |  |  |  |  |  |  |  |  |  |  |  |  |  |  |  |  |  |  |  |  |
| 14313019 |  | Vend Fab Q2&3 Peg Point #4b Cold Mass Fiducialitzation |  | 684d | 2012-03-05 A | 2013-08-30 A | 14313018 FS-500d | 100% |  | 2012-03-05 | 2014-11-26 |  |  |  |  | PROCUREMENT>$50K 69 NO ESCALATION; PROCUREMENT<$50K 60 NO ESCALATION | 112,900 |  |  |  | 112900 | 112900 | FENKER H | 1 | 1 |  | P | HOWARD F |  |  |  |  | 11-017 | 11-026 | 12-036F |  |  |  | 0 | 112900 | 11290000 | 100 | 4313 | 12-012 |  |  |  |  |  |  |  |  |  |  |  |  |  |  |  |  |  |  |  |
| 14313019a |  | Vend Fab Q2&3 Peg Point #5 Shipment |  | 702d | 2012-03-05 A | 2013-08-30 A | 14313019 FS-500d | 100% |  | 2012-03-05 | 2014-12-31 |  |  |  |  | PROCUREMENT>$50K 69 NO ESCALATION | 1,321,000 |  |  |  | 1321000 | 1321000 | FENKER H | 1 | 1 |  | P | HOWARD F |  |  |  |  | 11-017 | 11-026 | 12-036F |  |  |  | 0 | 1321000 | 132100000 | 100 | 4313 | 12-012 |  |  |  |  |  |  |  |  |  |  |  |  |  |  |  |  |  |  |  |
| 14313P4LOE |  | Q2&3- P-4 Contract Mngmnt for Q2-3 |  | 248d | 2012-10-01 A | 2013-08-30 A | 14313P3LOE | 100% |  | 2012-10-01 | 2013-09-30 |  |  |  |  | TRAVEL; MECH DES [73.55 h]; MECH ENG [404.51 h] | 44,310.76 | 32,926.57 | 100 | 100 | 8164.7412 | 44310.756376 | FENKER H | 1 | 1 | 07-034 | E | HOWARD F | 08-048 | 09-022 |  | 10-069 | 11-017 | 11-026 | 12-036F | 8.06451612 | 91.93548387 |  |  |  |  |  |  | 12-012 |  |  |  | 14313P4LOE |  |  |  |  |  |  |  |  |  |  |  |  |  |  |  |
| 14313030 |  | FDR Site Inspection |  | 20d | 2013-08-30 A | 2013-08-30 A | 14313015 FS-20d | 100% |  | 2013-10-08 | 2013-11-04 |  |  |  |  | MECH ENG [40 h]; TRAVEL | 12,346.83 | 2,894.4 |  |  | 12164.83 | 12164.83 | FENKER H | 1 | 1 | 07-034 | H | HOWARD F | 08-048 |  | 10-008 | 10-069 | 11-017 | 11-026 | 12-036F |  |  |  |  |  |  |  |  | 12-012 |  |  |  | 14313030 |  |  |  |  |  |  |  |  |  |  |  |  |  |  |  |
| 14313220 |  | Q2 and Q3 Coil Inspection |  | 53d | 2013-08-30 A | 2013-08-30 A | 14313017 FS-45d | 100% |  | 2013-12-30 | 2014-03-17 |  |  |  |  | MECH ENG [40 h]; TRAVEL | 7,666.82 | 2,894.4 |  |  | 7484.82 | 7484.82 | FENKER H | 1 | 1 | 07-034 | H | HOWARD F | 08-048 |  | 10-008 | 10-069 | 11-017 | 11-026 | 12-036F |  |  |  |  |  |  |  |  | 12-012 |  |  |  | 14313220 |  |  |  |  |  |  |  |  |  |  |  |  |  |  |  |
| 14313280 |  | Re-Baseline Actuals Adjustment |  | 1d | 2013-08-30 A | 2013-08-30 A |  | 100% |  | 2013-09-03 | 2013-09-03 |  |  |  |  | PROCUREMENT>$50K 69 NO ESCALATION | -2,650,807.51 |  |  |  |  |  |  |  |  |  |  |  |  |  |  |  |  |  |  |  |  |  |  |  |  | 100 |  |  |  |  |  |  | ADJ |  |  |  |  |  |  |  |  |  |  |  |  |  |  |
| 24313015 |  | Vend Fab Q2&3 Peg Point #2 Final Design Review |  | 43d | 2013-09-03 A | 2013-10-21 A | 9-130M FS+228d | 100% |  | 2013-09-03 | 2013-10-31 |  |  |  | 8/5 M-F w/JLAB Holidays ReBaseline | PROCUREMENT<$50K 60 NO ESCALATION; PROCUREMENT>$50K 69 NO ESCALATION | 489,700.13 |  |  |  |  | 489700.13 | FENKER H | 1 | 1 | 07-034 | P | HOWARD F | 08-048 |  | 10-008 | 10-069 | 11-017 | 11-026 | 12-036F |  |  |  | 0 | 489700.13 | 48970013 | 100 | 4313 | 12-012 | 09-012 | NB |  |  |  | OPEN OBLIGATION | 24313015 | Y | 13-006F | OB | YES | 13-015 | PR | OB |  |  |  |  |  |
| 24313017 |  | Vend Fab Q2&3 Peg Point #3 Cryostat Component Complete |  | 408d | 2013-09-03 A | 2015-04-30 | 24313030 FS-186d, 24313030a FS-20d, 24313015 FS-43d |  | 365d |  |  | 1d | 0d |  | 8/5 M-F w/JLAB Holidays ReBaseline | PROCUREMENT<$50K 60 NO ESCALATION; PROCUREMENT>$50K 69 NO ESCALATION | 432,250 |  |  |  |  | 0 | FENKER H | 1 | 1 | 07-034 | P | HOWARD F | 08-048 | 09-022 | 10-008 | 10-069 | 11-017 | 11-026 | 12-036F |  |  |  | 432250 | 0 | 0 | 100 | 4313 | 12-012 | 09-012 |  |  |  |  | OPEN OBLIGATION | 24313017 | Y | 13-006F | OB | YES | 13-015 | PR | OB |  |  |  |  |  |
| 24313019 |  | Vend Fab Q2&3 Peg Point #4 Cold Mass Fiducialitzation |  | 449d | 2013-09-03 A | 2015-06-30 | 24313017 FS-408d |  | 406d |  |  | 49d | 0d |  | 8/5 M-F w/JLAB Holidays ReBaseline | PROCUREMENT>$50K 69 NO ESCALATION; PROCUREMENT<$50K 60 NO ESCALATION | 432,250 |  |  |  |  | 0 | FENKER H | 1 | 1 |  | P | HOWARD F |  |  |  |  | 11-017 | 11-026 | 12-036F |  |  |  | 432250 | 0 | 0 | 100 | 4313 | 12-012 |  |  |  |  |  | OPEN OBLIGATION | 24313019 |  | 13-006F | OB | YES | 13-015 | PR | OB |  |  |  |  |  |
| 24313019a |  | Vend Fab Q2&3 Peg Point #5 Shipment |  | 513d | 2013-09-03 A | 2015-09-30 | 24313019 FS-449d |  | 470d |  |  | 6d | 0d |  | 8/5 M-F w/JLAB Holidays ReBaseline | PROCUREMENT>$50K 69 NO ESCALATION | 1,321,000 |  |  |  |  | 0 | FENKER H | 1 | 1 |  | P | HOWARD F |  |  |  |  | 11-017 | 11-026 | 12-036F |  |  |  | 1321000 | 0 | 0 | 100 | 4313 | 12-012 |  |  |  |  |  | OPEN OBLIGATION | 24313019a | Y | 13-006 | OB | YES | 13-015 | PR | OB |  |  |  |  |  |
| 24313019b |  | Vend Fab Q2&3 Peg Point #6 Final Acceptance |  | 571d | 2013-09-03 A | 2015-12-23 | 24313235 FS-679d, 24313019a FS-513d |  | 528d |  |  | 64d | 36d |  | 8/5 M-F w/JLAB Holidays ReBaseline | PROCUREMENT>$50K 69 NO ESCALATION | 146,100 |  |  |  |  | 0 | FENKER H | 1 | 1 |  | P | HOWARD F |  |  |  |  | 11-017 | 11-026 | 12-036F |  |  |  | 146100 | 0 | 0 | 100 | 4313 |  |  |  |  |  |  | OPEN OBLIGATION | 24313019b |  | 13-006 | OB | YES | 13-015 | PR | OB |  |  |  |  |  |
| 24313030a |  | FDR Site Inspection FY14 |  | 3d | 2013-09-03 A | 2013-10-21 A | 24313030 FS-60d | 100% |  | 2013-10-01 | 2013-10-03 |  |  |  | 8/5 M-F w/JLAB Holidays ReBaseline | TRAVEL; MECH ENG [6 h] | 1,896.81 | 443.62 |  |  |  | 948.405 | FENKER H | 1 | 1 | 07-034 | H | HOWARD F | 08-048 |  | 10-008 | 10-069 | 11-017 | 11-026 | 12-036F |  |  |  |  |  |  |  |  | 12-012 |  |  |  |  |  |  | 24313030 |  | 13-006F |  |  | 13-015 | PR |  | 948.405 | PE | PE | 14-001 |  |
| 24313280 |  | Planning Package SigmaPhi Quads (second winding station) |  | 161d | 2013-09-03 A | 2013-10-21 A | 9-130M FS+228d | 100% |  | 2013-09-03 | 2014-04-30 |  |  |  | 8/5 M-F w/JLAB Holidays ReBaseline | PROCUREMENT>$50K 69 NO ESCALATION | 100,000 |  |  |  |  | 100000 | FENKER H | 1 | 1 |  | D | HOWARD F |  |  |  |  |  |  |  |  |  |  | 0 | 100000 | 10000000 | 100 |  |  |  |  |  |  |  |  | 24313280 |  | 13-006 | EV |  | 13-015 | PR | OB |  |  |  |  | Pat |
| 24313P4LOE |  | Q2&3- P-4 Contract Mngmnt for Q2-3 |  | 20d | 2013-09-03 A | 2013-09-30 A | 9-130M FS+228d | 100% |  |  |  |  |  |  | 8/5 M-F w/JLAB Holidays ReBaseline | MECH DES [6.45 h]; MECH ENG [35.47 h]; TRAVEL | 3,885.66 | 2,887.26 |  |  |  | 0 | FENKER H | 1 | 1 | 07-034 | E | HOWARD F | 08-048 | 09-022 |  | 10-069 | 11-017 | 11-026 | 12-036F |  |  |  |  |  |  |  |  | 12-012 |  |  |  |  |  | OPEN OBLIGATION | 24313P4LOE |  | 13-006F |  |  | 13-015 | PR |  | 3885.665473 | PE | PE |  |  |
| 24313030 |  | FDR Site Inspection FY13 |  | 20d | 2013-09-06 A | 2013-10-21 A | 24313015 FS-40d | 100% |  | 2013-10-01 | 2013-10-28 |  |  |  | 8/5 M-F w/JLAB Holidays ReBaseline | TRAVEL; MECH ENG [34 h] | 10,494.81 | 2,519.13 |  |  |  | 5208.135 | FENKER H | 1 | 1 | 07-034 | H | HOWARD F | 08-048 |  | 10-008 | 10-069 | 11-017 | 11-026 | 12-036F |  |  |  |  |  |  |  |  | 12-012 |  |  |  |  |  |  | 24313030 |  | 13-006F |  |  | 13-015 | PR |  | 5208.135 | PE | PE |  |  |
| 24313P5LOE |  | Q2&3- P-5 Contract Mngmnt for Q2-3 |  | 247d | 2013-10-01 A | 2014-09-30 | 24313P4LOE | 9% | 224d | 2013-11-01 | 2014-10-31 | 354d | 0d |  | 8/5 M-F w/JLAB Holidays ReBaseline | MECH DES [20 h]; MECH ENG [440 h]; TRAVEL | 40,269.71 | 3,154.89 | 100 | 100 |  | 3749.110001 | FENKER H | 1 | 1 | 07-034 | E | HOWARD F | 08-048 | 09-022 |  | 10-069 | 11-017 | 11-026 | 12-036F | 90.6882591 | 9.31174089 |  |  |  |  |  |  | 12-012 |  |  |  |  |  |  | 24313P5LOE |  | 13-006 |  |  | 13-015 | PR |  |  | PE | PE | 14-001 |  |
| 24313P6LOE |  | Q2&3- P-6 Contract Mngmnt for Q2-3 |  | 247d | 2014-10-01 | 2015-10-01 | 24313P5LOE |  |  |  |  | 439d | 0d |  | 8/5 M-F w/JLAB Holidays ReBaseline | MECH ENG [440 h]; TRAVEL | 53,492.8 |  | 100 | 100 |  | 0 | FENKER H | 1 | 1 |  | E | HOWARD F |  |  |  |  |  |  |  | 100 | 0 |  |  |  |  |  |  |  |  |  |  |  |  |  | 24313P6LOE |  | 13-006 |  |  | 13-015 | PR |  |  | PE | PE | 14-001 |  |
| 24313220 |  | Q2 and Q3 Coil Inspection |  | 49d | 2014-10-27 | 2015-01-15 | 24313017 FS-123d |  |  |  |  | 287d | 259d |  | 8/5 M-F w/JLAB Holidays ReBaseline | TRAVEL; MECH ENG [40 h] | 7,816.11 |  |  |  |  | 0 | FENKER H | 1 | 1 | 07-034 | H | HOWARD F | 08-048 |  | 10-008 | 10-069 | 11-017 | 11-026 | 12-036F |  |  |  |  |  |  |  |  | 12-012 |  |  |  |  |  |  | 24313220 |  |  |  |  | 13-015 | PR |  |  | PE | PE | 14-001 |  |
| 24313230 |  | Q2 and Q3- Insp Cold Mass |  | 6d | 2014-12-22 | 2015-01-08 | 24313019 FS-126d, 2-30M FS-240d |  |  |  |  | 292d | 264d |  | 8/5 M-F w/JLAB Holidays ReBaseline | TRAVEL; MECH ENG [40 h] | 7,970.16 |  |  |  |  | 0 | FENKER H | 1 | 1 | 07-034 | H | HOWARD F | 08-048 |  | 10-008 | 10-069 | 11-017 | 11-026 | 12-036F |  |  |  |  |  |  |  |  | 12-012 |  |  |  |  |  |  | 24313230 |  | 13-006 |  |  | 13-015 | PR |  |  | PE | PE | 14-001 |  |
| 24313235 |  | Q2 and Q3 witness Pressure Tests |  | 36d | 2015-05-08 | 2015-06-30 | 2-31M FS-100d, 2-30M FS-40d, 24313019a FS-100d |  |  |  |  | 337d | 273d |  | 8/5 M-F w/JLAB Holidays ReBaseline | TRAVEL | 4,983.36 |  |  |  |  | 0 | FENKER H | 1 | 1 | 07-034 | H | HOWARD F | 08-048 |  |  | 10-069 | 11-017 | 11-026 | 12-036 |  |  |  |  |  |  |  | 4313 |  | 09-012 |  |  |  |  | NO PROC. | 24313235 |  | 13-006 |  |  | 13-015 | PR |  |  |  | PE | 14-001 |  |
| 24313275 |  | Q2&Q3 Drawing Validation |  | 100d | 2015-09-02 | 2016-02-03 | 2-31M FS-20d, 24313019a FS-20d, 2-30M |  |  |  |  | 28d | 0d |  | 8/5 M-F w/JLAB Holidays ReBaseline | MECH DES [480 h] | 24,624 |  |  |  |  | 0 | FENKER H | 1 | 1 | 07-034 | S | HOWARD F | 08-048 | 09-022 |  | 10-069 | 11-017 | 11-026 | 12-036 |  |  |  |  |  |  |  |  |  | 09-012 | ST |  |  |  |  | 24313275 |  | 13-006 |  |  | 13-015 | PR |  |  | PE |  | 14-001 | Pat |
| 24313P6LOE5 |  | Q2&3- P-7 Contract Mngmnt for Q2-3 |  | 56d | 2015-10-02 | 2015-12-22 | 24313P5LOE, 24313P6LOE |  |  |  |  | 439d | 501d |  | 8/5 M-F w/JLAB Holidays ReBaseline | MECH ENG [110 h] | 8,213.7 |  | 100 | 100 |  | 0 | FENKER H | 1 | 1 |  | E | HOWARD F |  |  |  |  |  |  |  | 100 | 0 |  |  |  |  |  |  |  |  |  |  |  |  |  | 24313P6LOE5 |  | 13-006 |  |  | 13-015 | PR |  |  | PE | PE | 14-001 |  |
| 24313270M |  | Q2 and Q3 Contract complete | milestone | 0d | 2016-02-03 | 2016-02-03 | 24313230, 24313P5LOE, 28236010, 24313220, 24313280, 24313275, 24313019b FS-14d, 28236020 |  |  |  |  | 28d |  |  | 8/5 M-F w/JLAB Holidays ReBaseline |  |  |  |  |  |  | 0 | FENKER H | 1 | 1 | 07-034 | M | HOWARD F | 08-048 | 09-022 |  | 10-069 | 11-017 | 11-026 | 12-036 |  |  |  |  |  |  |  |  | 12-012 | 09-012 |  |  |  |  |  | 24313270M |  | 13-006 |  |  | 13-015 | PR |  |  |  |  |  |  |

Notes:
- 14313010: Steps: Insulation and preparation of SC cable (done); Magnet Traveler complete (Manufacturing Plan) (done); Winding Tooling Complete (done); Final Design Review (done); Stress Analysis complete (done); Quench Protection Analysis (done); DC System Analysis complete (done); Instrumentation design (done); 100% Drawing package (done); Analysis of Pressure Vessels (done); Vessel weld design & analysis (done); Weld qualification (done); Welder qualifications (done); Trial Winding Complete (done)
- 14313015: Steps: Insulation and preparation of SC cable (done); Magnet Traveler complete (Manufacturing Plan) (done); Winding Tooling Complete (done); Final Design Review (done); Stress Analysis complete (done); Quench Protection Analysis (done); DC System Analysis complete (done); Instrumentation design (done); 100% Drawing package (done); Analysis of Pressure Vessels (done); Vessel weld design & analysis (done); Weld qualification (done); Welder qualifications (done); Trial Winding Complete (done)
- 24313015: Explanation: Vendor invoiced 50% and Howard Accrued / 50% 11/4/2013
- 24313275: Steps: 1st 25% of vendor-supplied drawings checked; 2nd 25% of vendor-supplied drawings checked; 3rd 25% of vendor-supplied drawings checked; 4th 25% of vendor-supplied drawings checked

| ID | WBS | Activity | Type | Duration | Start | Finish | Predecessors | Complete | Remaining | Planned start | Planned finish | Total float | Free float | Calendar | Resources | Cost | Actual cost | LOE Divider | LOE Multiplier | Calculated Remaining Total Cost | MONTHLY EV COST | RESP - Responsibility | STRT%COMP for CM EVM | FNSH%COMP for CM EVM | CR 07-034 | EVMS Reporting Codes | CAM RESPONSIBLE | CR 08-048 | CR 09-022 | CR 10-008 | CR 10-069 | CR 11-026 | CR 13-006 | Milestone Level | Profile change | 12 GEV MAJOR PROCUREMENT CATAGORY | CR 09-012 | CR 10-076 | CR 11-017 | CR 11-046 | CR 12-012 | CR 12-036 | Remaining Material Cost Based on % Compl | Claimed Material Cost Based on % Complet | Initial Claimed Material Calc | Claimed Material Divider | Activities with Steps | Phil Dev | MARCH!!! | Specification | LOE % Pre Calc | LOE % | CR 08-052 | ReBaseline Actuals Adjustment | BOE NOTES | Original Activity ID Rebaseline | SC Magnet Dates | BOE Procurement | BOE Adder | Post Rebaseline | Obligated Prior to Rebaseline | CR 13-015 | PRIOR MONTH EV COST | BOE Labor | BOE Expenses | CR 14-001 | CR 12-054 | Pat's Code |
| --- | --- | --- | --- | --- | --- | --- | --- | --- | --- | --- | --- | --- | --- | --- | --- | --- | --- | --- | --- | --- | --- | --- | --- | --- | --- | --- | --- | --- | --- | --- | --- | --- | --- | --- | --- | --- | --- | --- | --- | --- | --- | --- | --- | --- | --- | --- | --- | --- | --- | --- | --- | --- | --- | --- | --- | --- | --- | --- | --- | --- | --- | --- | --- | --- | --- | --- | --- | --- |
|  | 4 | **1.4.3.1.4 DIPOLE** |  |  | 2009-12-14 | 2015-10-01 |  |  |  |  |  |  |  |  |  |  |  |  |  |  |  |  |  |  |  |  |  |  |  |  |  |  |  |  |  |  |  |  |  |  |  |  |  |  |  |  |  |  |  |  |  |  |  |  |  |  |  |  |  |  |  |  |  |  |  |  |  |  |
| 14314P1LOE |  | Dipole- P-1 Contract Mngmnt for Dipole |  | 198d | 2009-12-14 A | 2010-09-30 A | 9-100M FS+50d | 100% |  |  |  |  |  |  | TRAVEL; MECH DES [120 h]; MECH ENG [280 h] | 32,657.08 | 23,866.8 | 100 | 100 | 0 | 32657.081426 | FENKER H | 1 | 1 | 07-034 | E | HOWARD F | 08-048 | 09-022 | 10-008 | 10-069 | 11-026 | 13-006F |  |  |  |  |  |  |  |  |  |  |  |  |  |  |  |  |  |  |  |  |  |  |  |  |  |  |  |  |  |  |  |  |  |  |  |
| 14314000M5 |  | Dipole- Award Contract for SHMS Dipole Mag | milestone | 0d | 2010-09-30 A | 2010-09-30 A | 122312070, 9-100M | 100% |  | 2010-10-01 | 2010-10-01 |  |  |  |  |  |  |  |  |  | 0 | FENKER H | 1 | 1 |  | M | HOWARD F | 08-048 |  | 10-008 |  |  |  | 4 | C |  |  |  |  |  |  |  |  |  |  |  |  |  |  |  |  |  |  |  |  |  |  |  |  |  |  |  |  |  |  |  |  |  |
| 14314002 |  | Dipole- Finalize Dsgn for Dipole Mag (Original Expenses) |  | 18d | 2010-09-30 A | 2010-10-25 A | 14314000M5 | 100% |  |  |  |  |  |  | TRAVEL | 859.49 |  |  |  | 0 | 859.49 | FENKER H | 1 | 1 | 07-034 | H | HOWARD F | 08-048 |  | 10-008 | 10-069 | 11-026 |  |  |  | 4314 | 09-012 | 10-076 | 11-017 | 11-046 | 12-012 | 12-036F |  |  |  |  |  |  |  |  |  |  |  |  |  |  |  |  |  |  |  |  |  |  |  |  |  |  |
| 14314003 |  | Dipole- Contractor Expenses |  | 1d | 2010-09-30 A | 2010-09-30 A | 14314000M5 | 100% |  |  |  |  |  |  | PROCUREMENT>$50K 69 | 59,334.4 |  |  |  | 0 | 59334.404785 | FENKER H | 1 | 1 | 07-034 | P | HOWARD F | 08-048 |  | 10-008 | 10-069 | 11-026 |  |  |  | 4314 |  | 10-076 | 11-017 | 11-046 | 12-012 | 12-036F | 0 | 59334.404785 | 5933440.4785 | 100 |  |  |  |  |  |  |  |  |  |  |  |  |  |  |  |  |  |  |  |  |  |  |
| 14314003a |  | Dipole Contractor Expenses Reverse Entry |  | 1d | 2010-09-30 A | 2010-09-30 A | 14314003 FS+22d | 100% |  |  |  |  |  |  | PROCUREMENT>$50K 69 | -59,334.4 |  |  |  |  |  | FENKER H | 1 | 1 |  | P | HOWARD F |  |  |  |  | 11-026 |  |  |  | 4314 |  | 10-076 | 11-017 | 11-046 | 12-012 | 12-036F |  |  |  | 100 |  |  |  |  |  |  |  |  |  |  |  |  |  |  |  |  |  |  |  |  |  |  |
| 14314004 |  | Vend Fab Dipole Intermediate Design Review Peg Point #1 |  | 288d | 2010-09-30 A | 2011-11-28 A | 14314003, 9-110M FS-1d, 14314003a, 14314002 FS-220d | 100% |  |  |  |  |  |  | PROCUREMENT<$50K 60 NO ESCALATION; PROCUREMENT>$50K 69 NO ESCALATION | 97,500 |  |  |  | 0 | 97500 | FENKER H | 1 | 1 | 07-034 | P | HOWARD F | 08-048 |  | 10-008 | 10-069 | 11-026 |  |  |  | 4314 |  | 10-076 | 11-017 | 11-046 | 12-012 | 12-036F | 0 | 97500 | 9750000 | 100 |  |  |  |  |  |  |  |  |  |  |  |  |  |  |  |  |  |  |  |  |  |  |
| 14314010 |  | Vend Fab Dipole Coil Tooling Delivered Peg Point #2 |  | 463d | 2010-09-30 A | 2012-08-13 A | 14314036 FS-163d, 14314004 FS-163d | 100% |  |  |  |  |  |  | PROCUREMENT>$50K 69 NO ESCALATION | 461,520 |  |  |  | 0 | 461520 | FENKER H | 1 | 1 | 07-034 | S | HOWARD F | 08-048 |  | 10-008 | 10-069 | 11-026 |  |  |  | 4314 | 09-012 | 10-076 | 11-017 | 11-046 | 12-012 | 12-036F | 0 | 461520 | 46152000 | 100 | ST | MP |  |  |  |  |  |  |  |  |  |  |  |  |  |  |  |  |  |  |  |  |
| 14314012 |  | Vend Fab Dipole Final Design Review Peg Point #3 |  | 576d | 2010-09-30 A | 2013-08-30 A | 14315020 FS-500d, 14314010 FS-249d | 100% |  | 2010-09-30 | 2013-01-31 |  |  |  | PROCUREMENT>$50K 69 NO ESCALATION | 97,500 |  |  |  | 97500 | 97500 | FENKER H | 1 | 1 | 07-034 | S | HOWARD F | 08-048 | 09-022 | 10-008 | 10-069 | 11-026 |  |  |  | 4314 | 09-012 | 10-076 | 11-017 | 11-046 | 12-012 | 12-036F | 0 | 97500 | 9750000 | 100 | ST | MP | XX |  |  |  |  |  |  |  |  |  |  |  |  |  |  |  |  |  |  |  |
| 14314015 |  | Vend Fab Dipole Second Coil Wind Peg Point #4a |  | 702d | 2010-09-30 A | 2013-08-30 A | 14314012 FS-269d, 14314045 FS-309d | 100% |  | 2010-09-30 | 2013-07-31 |  |  |  | PROCUREMENT>$50K 69 NO ESCALATION | 43,480 |  |  |  | 43480 | 43480 | FENKER H | 1 | 1 | 07-034 | P | HOWARD F | 08-048 |  | 10-008 | 10-069 | 11-026 |  |  |  |  |  | 10-076 | 11-017 | 11-046 | 12-012 | 12-036F | 0 | 43480 | 4348000 | 100 |  |  |  | 14314015 |  |  |  |  |  |  |  |  |  |  |  |  |  |  |  |  |  |  |
| 14314P2LOE |  | Dipole- P-2 Contract Mngmnt for Dipole |  | 248d | 2010-10-01 A | 2011-09-30 A | 14314P1LOE | 100% |  |  |  |  |  |  | MECH DES [80 h]; MECH ENG [440 h]; TRAVEL | 42,703.09 | 33,632.4 | 100 | 100 | 0 | 42703.09 | FENKER H | 1 | 1 | 07-034 | E | HOWARD F | 08-048 | 09-022 |  | 10-069 | 11-026 | 13-006F |  |  |  |  |  |  |  |  |  |  |  |  |  |  |  |  |  | 8.46774193 | 91.53225806 |  |  |  |  |  |  |  |  |  |  |  |  |  |  |  |  |
| 14314020 |  | Vend Fab Dipole Second Coil Wind Peg Point #4b |  | 623d | 2011-02-01 A | 2013-08-30 A | 9-110M, 14314015 FS-275d | 100% |  | 2011-02-01 | 2013-07-31 |  |  |  | PROCUREMENT<$50K 60 NO ESCALATION; PROCUREMENT>$50K 69 NO ESCALATION | 348,450 |  |  |  | 348450 | 348450 | FENKER H | 1 | 1 | 07-034 | P | HOWARD F | 08-048 |  | 10-008 | 10-069 | 11-026 |  |  | C | 4314 | 09-012 | 10-076 | 11-017 | 11-046 | 12-012 | 12-036F | 0 | 348450 | 34845000 | 100 |  |  |  |  |  |  |  |  |  |  |  |  |  |  |  |  |  |  |  |  |  |  |
| 14314025 |  | Vend Fab Dipole Outer Vessel Completed Peg Point #5a |  | 665d | 2011-02-01 A | 2013-08-30 A | 14314020 FS-275d, 14314047 FS-487d | 100% |  | 2011-02-01 | 2013-09-30 |  |  |  | PROCUREMENT>$50K 69 NO ESCALATION | 251,550 |  |  |  | 251550 | 251550 | FENKER H | 1 | 1 | 07-034 | P | HOWARD F | 08-048 |  | 10-008 | 10-069 | 11-026 |  |  |  | 4314 | 09-012 | 10-076 | 11-017 | 11-046 | 12-012 | 12-036F | 0 | 251550 | 25155000 | 100 |  |  |  |  |  |  |  |  |  |  |  |  |  |  |  |  |  |  |  |  |  |  |
| 14314P3LOE |  | Dipole- P-3 Contract Mngmnt for Dipole |  | 247d | 2011-10-03 A | 2012-09-28 A | 14314P2LOE | 100% |  |  |  |  |  |  | TRAVEL; MECH DES [80 h]; MECH ENG [440 h] | 44,066.45 | 34,706.4 | 100 | 100 | 0 | 44066.45 | FENKER H | 1 | 1 | 07-034 | E | HOWARD F | 08-048 | 09-022 |  | 10-069 | 11-026 | 13-006F |  |  |  |  |  |  |  |  |  |  |  |  |  |  |  |  |  | 7.69230769 | 92.3076923 |  |  |  |  |  |  |  |  |  |  |  |  |  |  |  |  |
| 14314036 |  | Dipole- Intermediate Design Review |  | 18d | 2011-11-01 A | 2011-11-28 A | 14314004 FS-20d | 100% |  |  |  |  |  |  | MECH ENG [40 h]; TRAVEL | 7,340.14 | 2,804.8 |  |  | 0 | 7253.34 | FENKER H | 1 | 1 | 07-034 | D | HOWARD F | 08-048 | 09-022 | 10-008 | 10-069 | 11-026 |  |  |  | 4314 |  | 10-076 | 11-017 | 11-046 | 12-012 | 12-036F |  |  |  |  |  |  |  |  |  |  |  |  |  |  |  |  |  |  |  |  |  |  |  |  |  |  |
| 14314027 |  | Vend Fab Dipole Outer Vessel Completed Peg Point #5b |  | 395d | 2012-03-05 A | 2013-08-30 A | 14314047 FS-245d, 14314025 FS-460d, 9-070M, 9-120M, 14314020 FS-245d | 100% |  | 2012-03-05 | 2013-09-30 |  |  |  | PROCUREMENT<$50K 60 NO ESCALATION; PROCUREMENT>$50K 69 NO ESCALATION | 185,325 |  |  |  | 185325 | 185325 | FENKER H | 1 | 1 | 07-034 | P | HOWARD F | 08-048 |  | 10-008 | 10-069 | 11-026 |  |  |  |  |  | 10-076 | 11-017 | 11-046 | 12-012 | 12-036F | 0 | 185325 | 18532500 | 100 |  |  |  | 14314027 |  |  |  |  |  |  |  |  |  |  |  |  |  |  |  |  |  |  |
| 14314030 |  | Vend Fab Dipole Factory Test Completed Peg Point #6 |  | 558d | 2012-03-05 A | 2013-08-30 A | 14314027 FS-475d | 100% |  | 2012-03-05 | 2014-05-30 |  |  |  | PROCUREMENT>$50K 69 NO ESCALATION | 333,300 |  |  |  | 333300 | 333300 | FENKER H | 1 | 1 | 07-034 | P | HOWARD F | 08-048 |  | 10-008 | 10-069 | 11-026 |  |  |  | 4314 | 09-012 | 10-076 | 11-017 | 11-046 | 12-012 | 12-036F | 0 | 333300 | 33330000 | 100 |  |  |  |  |  |  |  |  |  |  |  |  |  |  |  |  |  |  |  |  |  |  |
| 14314045 |  | Dipole- Final Design Review |  | 92d | 2012-05-01 A | 2012-09-10 A | 14314012 FS-500d | 100% |  |  |  |  |  |  | MECH ENG [40 h]; TRAVEL | 7,484.82 | 2,804.8 |  |  | 0 | 7484.82 | FENKER H | 1 | 1 | 07-034 | H | HOWARD F | 08-048 |  | 10-008 | 10-069 | 11-026 |  |  |  | 4314 | 09-012 | 10-076 | 11-017 | 11-046 | 12-012 | 12-036F |  |  |  |  |  |  |  |  |  |  |  |  |  |  |  |  |  |  |  |  |  |  |  |  |  |  |
| 14314P4LOE |  | Dipole- P-4 Contract Mngmnt for Dipole |  | 248d | 2012-10-01 A | 2013-08-30 A | 14314P3LOE | 100% |  | 2012-10-01 | 2013-09-30 |  |  |  | TRAVEL; MECH DES [73.55 h]; MECH ENG [294.19 h] | 36,327.99 | 24,943.8 | 100 | 100 | 6693.80712 | 36327.9942 | FENKER H | 1 | 1 | 07-034 | E | HOWARD F | 08-048 | 09-022 |  | 10-069 | 11-026 | 13-006F |  |  |  |  |  |  |  | 12-012 |  |  |  |  |  |  |  |  | 14314P4LOE | 8.06451612 | 91.93548387 |  |  |  |  |  |  |  |  |  |  |  |  |  |  |  |  |
| 14314P4TLOE |  | Dipole- P-4 Contract Extra Travel |  | 189d | 2013-01-02 A | 2013-08-30 A | 14314P4LOE FS-189d | 100% |  | 2013-02-01 | 2013-10-29 |  |  |  | TRAVEL | 13,233.86 |  | 100 | 100 | 3288.56 | 13233.86 | FENKER H | 1 | 1 |  | E | HOWARD F |  |  |  |  |  | 13-006 |  |  |  |  |  |  |  |  |  |  |  |  |  |  |  |  |  | 10.58201058 | 89.41798941 |  |  |  |  |  |  |  |  |  |  |  |  |  |  |  |  |
| 14314100 |  | Planning Package SigmaPhi Phase 1 (Coil Developement) |  | 61d | 2013-03-11 A | 2013-04-15 A | 9-130M FS+120d | 100% |  | 2013-04-01 | 2013-06-25 |  |  |  | PROCUREMENT>$50K 69 NO ESCALATION | 250,000 |  |  |  | 0 | 250000 | FENKER H | 1 | 1 |  | D | HOWARD F |  |  |  |  |  | 13-006 |  |  | 4314 |  |  |  |  |  |  | 0 | 250000 | 25000000 | 100 |  |  |  |  |  |  |  |  |  |  |  |  |  |  |  |  |  |  |  |  |  |  |
| 14314030a |  | Dipole Magnet Shipping |  | 54d | 2013-08-30 A | 2013-08-30 A | 14314030 | 100% |  | 2013-09-03 | 2013-11-15 |  |  |  |  |  |  |  |  |  | 0 | FENKER H | 1 | 1 | 07-034 | Z | HOWARD F | 08-048 | 09-022 |  | 10-069 | 11-026 |  |  |  | 4314 |  | 10-076 | 11-017 | 11-046 | 12-012 | 12-036 |  |  |  |  |  |  |  | 14314030a |  |  | 08-052 |  |  |  |  |  |  |  |  |  |  |  |  |  |  |  |
| 14314047 |  | Dipole Inspect Coil |  | 20d | 2013-08-30 A | 2013-08-30 A | 14314020 FS-20d | 100% |  | 2013-09-03 | 2013-09-30 |  |  |  | MECH ENG [40 h]; TRAVEL | 7,574.42 | 2,894.4 |  |  | 7484.82 | 7484.82 | FENKER H | 1 | 1 | 07-034 | H | HOWARD F | 08-048 | 09-022 |  | 10-069 | 11-026 |  |  |  | 4314 |  | 10-076 | 11-017 | 11-046 | 12-012 | 12-036F |  |  |  |  |  |  |  | 14314047 |  |  | 08-052 |  |  |  |  |  |  |  |  |  |  |  |  |  |  |  |
| 14314115 |  | Re-Baseline Actuals Adjustment |  | 1d | 2013-08-30 A | 2013-08-30 A |  | 100% |  | 2013-09-03 | 2013-09-03 |  |  |  | PROCUREMENT>$50K 69 NO ESCALATION | -944,650.63 |  |  |  |  |  |  |  |  |  |  |  |  |  |  |  |  |  |  |  |  |  |  |  |  |  |  |  |  |  | 100 |  |  |  |  |  |  |  | ADJ |  |  |  |  |  |  |  |  |  |  |  |  |  |  |
| 24314012 |  | Vend Fab Dipole Final Design Review Peg Point #3 |  | 43d | 2013-09-03 A | 2013-10-21 A | 9-130M FS+228d | 100% |  | 2013-09-03 | 2013-10-31 |  |  | 8/5 M-F w/JLAB Holidays ReBaseline | PROCUREMENT>$50K 69 NO ESCALATION | 97,500 |  |  |  |  | 97500 | FENKER H | 1 | 1 | 07-034 | P | HOWARD F | 08-048 | 09-022 | 10-008 | 10-069 | 11-026 | 13-006F |  |  | 4314 | 09-012 | 10-076 | 11-017 | 11-046 | 12-012 | 12-036F | 0 | 97500 | 9750000 | 100 | NB |  |  |  |  |  |  |  | OPEN OBLIGATION | 24314012 | Y | OB | YES | PR | OB |  |  |  |  |  |  |  |
| 24314020 |  | Vend Fab Dipole Second Coil Wind Peg Point #4 |  | 139d | 2013-09-03 A | 2014-03-31 | 24314012 FS-43d |  | 96d |  |  | 86d | 0d | 8/5 M-F w/JLAB Holidays ReBaseline | PROCUREMENT<$50K 60 NO ESCALATION; PROCUREMENT>$50K 69 NO ESCALATION | 391,930 |  |  |  |  | 0 | FENKER H | 1 | 1 | 07-034 | P | HOWARD F | 08-048 |  | 10-008 | 10-069 | 11-026 | 13-006F |  | C | 4314 | 09-012 | 10-076 | 11-017 | 11-046 | 12-012 | 12-036F | 391930 | 0 | 0 | 100 |  |  |  |  |  |  |  |  | OPEN OBLIGATION | 24314020 | Y | OB | YES | PR | OB | 13-015 |  |  |  |  |  |  |
| 24314027 |  | Vend Fab Dipole Outer Vessel Completed Peg Point #5 (F-12) |  | 267d | 2013-09-03 A | 2014-09-30 | 24314047 FS-245d, 24314020 FS-139d |  | 224d |  |  | 43d | 0d | 8/5 M-F w/JLAB Holidays ReBaseline | PROCUREMENT<$50K 60 NO ESCALATION; PROCUREMENT>$50K 69 NO ESCALATION | 436,875 |  |  |  |  | 0 | FENKER H | 1 | 1 | 07-034 | P | HOWARD F | 08-048 |  | 10-008 | 10-069 | 11-026 | 13-006F |  |  |  |  | 10-076 | 11-017 | 11-046 | 12-012 | 12-036F | 436875 | 0 | 0 | 100 |  |  |  |  |  |  |  |  | OPEN OBLIGATION | 24314027 | Y | OB | YES | PR | OB | 13-015 |  |  |  |  |  |  |
| 24314028 |  | Vend Fab Dipole Conductor 4K Testing Peg Point #5a |  | 77d | 2013-09-03 A | 2013-12-20 | 24314027 FS-267d |  | 34d |  |  | 43d |  | 8/5 M-F w/JLAB Holidays ReBaseline | PROCUREMENT<$50K 60 NO ESCALATION; PROCUREMENT>$50K 69 NO ESCALATION | 26,000.07 |  |  |  |  | 0 | FENKER H | 1 | 1 | 07-034 | P | HOWARD F | 08-048 |  | 10-008 | 10-069 | 11-026 | 13-006F |  |  |  |  | 10-076 | 11-017 | 11-046 | 12-012 | 12-036F | 26000.07 | 0 | 0 | 100 |  |  |  |  |  |  |  |  | OPEN OBLIGATION | 24314027 |  | OB | YES | PR | OB | 13-015 |  |  |  |  |  |  |
| 24314030 |  | Vend Fab Dipole Factory Test Completed Peg Point #6 |  | 386d | 2013-09-03 A | 2015-03-31 | 24314027 FS-267d, 24314028 FS-77d |  | 343d |  |  | 0d |  | 8/5 M-F w/JLAB Holidays ReBaseline | PROCUREMENT>$50K 69 NO ESCALATION | 333,300 |  |  |  |  | 0 | FENKER H | 1 | 1 | 07-034 | P | HOWARD F | 08-048 |  | 10-008 | 10-069 | 11-026 | 13-006 |  |  | 4314 | 09-012 | 10-076 | 11-017 | 11-046 | 12-012 | 12-036F | 333300 | 0 | 0 | 100 |  |  |  |  |  |  |  |  | OPEN OBLIGATION | 24314030 |  | OB | YES | PR | OB | 13-015 |  |  |  |  |  |  |
| 24314035 |  | Vend Fab Dipole Magnet Accepted Peg Point #7 |  | 492d | 2013-09-03 A | 2015-08-31 | 24314030 FS-386d |  | 449d |  |  | 1d |  | 8/5 M-F w/JLAB Holidays ReBaseline | PROCUREMENT>$50K 69 NO ESCALATION | 159,910 |  |  |  |  | 0 | FENKER H | 1 | 1 | 07-034 | P | HOWARD F | 08-048 | 09-022 |  | 10-069 | 11-026 | 13-006 |  |  | 4314 | 09-012 | 10-076 | 11-017 | 11-046 | 12-012 | 12-036F | 159910 | 0 | 0 | 100 |  |  |  |  |  |  | 08-052 |  | OPEN OBLIGATION | 24314035 |  | OB | YES | PR | OB | 13-015 |  |  |  |  |  |  |
| 24314P4LOE |  | Dipole- P-4 Contract Mngmnt for Dipole |  | 20d | 2013-09-03 A | 2013-09-30 A | 9-130M FS+228d | 100% |  | 2013-10-01 | 2013-10-28 |  |  | 8/5 M-F w/JLAB Holidays ReBaseline | MECH ENG [25.8 h]; TRAVEL; MECH DES [6.45 h] | 3,255.86 | 2,187.53 |  |  |  | 0 | FENKER H | 1 | 1 | 07-034 | E | HOWARD F | 08-048 | 09-022 |  | 10-069 | 11-026 | 13-006F |  |  |  |  |  |  |  | 12-012 |  |  |  |  |  |  |  |  |  |  |  |  |  | OPEN OBLIGATION | 24314P4LOE |  |  |  | PR |  | 13-015 | 3185.999663 | PE | PE |  |  |  |
| 24314P4TLOE |  | Dipole- P-4 Contract Extra Travel |  | 20d | 2013-09-03 A | 2013-09-30 A | 24314P4LOE FS-20d | 100% |  | 2013-10-01 | 2013-10-28 |  |  | 8/5 M-F w/JLAB Holidays ReBaseline | TRAVEL | 1,565.81 |  |  |  |  | 0 | FENKER H | 1 | 1 |  | E | HOWARD F |  |  |  |  |  | 13-006 |  |  |  |  |  |  |  |  |  |  |  |  |  |  |  |  |  |  |  |  |  |  | 24314P4TLOE |  |  |  | PR |  | 13-015 | 1565.81 | PE | PE |  |  |  |
| 24314P5LOE |  | Dipole- P-5 Contract Mngmnt for Dipole |  | 247d | 2013-10-01 A | 2014-09-30 | 24314P4TLOE | 9% | 224d | 2013-11-01 | 2014-10-31 | 495d | 0d | 8/5 M-F w/JLAB Holidays ReBaseline | MECH ENG [320 h]; TRAVEL | 54,851.4 | 2,224.98 | 100 | 100 |  | 5106.66534 | FENKER H | 1 | 1 |  | E | HOWARD F |  |  |  |  |  | 13-006 |  |  |  |  |  |  |  |  |  |  |  |  |  |  |  |  |  | 90.6882591 | 9.31174089 |  |  |  | 24314P5LOE |  |  |  | PR |  | 13-015 |  | PE | PE | 14-001 |  |  |
| 24314110 |  | Planning Package SigmaPhi Phase 2 ( Coil Development, VPI ) |  | 128d | 2014-02-03 | 2014-08-01 | 9-140M FS+80d |  |  |  |  | 783d | 845d | 8/5 M-F w/JLAB Holidays ReBaseline | PROCUREMENT>$50K 69 NO ESCALATION | 534,000 |  |  |  |  | 0 | FENKER H | 1 | 1 |  | D | HOWARD F |  |  |  |  |  | 13-006 |  |  | 4314 |  |  |  |  |  |  | 534000 | 0 | 0 | 100 |  |  |  |  |  |  |  |  |  | 24314110 |  | EV |  | PR |  | 13-015 |  |  |  |  |  |  |
| 24314047 |  | Dipole Inspect Coil |  | 20d | 2014-03-04 | 2014-03-31 | 24314020 FS-20d |  |  |  |  | 192d | 149d | 8/5 M-F w/JLAB Holidays ReBaseline | MECH ENG [40 h]; TRAVEL | 7,816.11 |  |  |  |  | 0 | FENKER H | 1 | 1 | 07-034 | H | HOWARD F | 08-048 | 09-022 |  | 10-069 | 11-026 | 13-006F |  |  | 4314 |  | 10-076 | 11-017 | 11-046 | 12-012 | 12-036F |  |  |  |  |  |  |  |  |  |  | 08-052 |  | NO PROC | 24314047 |  |  |  | PR |  | 13-015 |  | PE | PE | 14-001 |  |  |
| 24314048 |  | Dipole Inspect Cold Mass |  | 20d | 2014-09-17 | 2014-10-14 | 24314027 FS-10d, 2-29M FS-290d |  |  |  |  | 205d | 143d | 8/5 M-F w/JLAB Holidays ReBaseline | TRAVEL; MECH ENG [40 h] | 7,970.16 |  |  |  |  | 0 | FENKER H | 1 | 1 | 07-034 | H | HOWARD F | 08-048 | 09-022 |  | 10-069 | 11-026 | 13-006 |  |  | 4314 |  | 10-076 | 11-017 | 11-046 | 12-012 | 12-036 |  |  |  |  |  |  |  |  |  |  | 08-052 |  |  | 24314048 |  |  |  | PR |  | 13-015 |  | PE | PE | 14-001 | 12-054 |  |
| 24314P6LOE |  | Dipole- P-6 Contract Mngmnt for Dipole |  | 247d | 2014-10-01 | 2015-10-01 | 24314P5LOE, 24314P4TLOE |  |  |  |  | 495d | 557d | 8/5 M-F w/JLAB Holidays ReBaseline | MECH ENG [320 h]; TRAVEL | 54,851.4 |  | 100 | 100 |  | 0 | FENKER H | 1 | 1 |  | E | HOWARD F |  |  |  |  |  | 13-006 |  |  |  |  |  |  |  |  |  |  |  |  |  |  |  |  |  | 100 | 0 |  |  |  | 24314P6LOE |  |  |  | PR |  | 13-015 |  | PE | PE | 14-001 |  |  |
| 24314049 |  | Dipole Witness Final Factory Tests |  | 40d | 2015-02-04 | 2015-03-31 | 24314030 FS-40d, 2-29M FS-90d |  |  |  |  | 185d | 123d | 8/5 M-F w/JLAB Holidays ReBaseline | MECH ENG [40 h]; TRAVEL | 7,970.16 |  |  |  |  | 0 | FENKER H | 1 | 1 | 07-034 | H | HOWARD F | 08-048 | 09-022 |  | 10-069 | 11-026 | 13-006 |  |  | 4314 |  | 10-076 | 11-017 | 11-046 | 12-012 | 12-036 |  |  |  |  |  |  |  |  |  |  | 08-052 |  |  | 24314049 |  |  |  | PR |  | 13-015 |  | PE | PE | 14-001 |  |  |
| 24314030a |  | Dipole Magnet Shipping |  | 54d | 2015-03-04 | 2015-05-18 | 24314030 FS-20d |  |  |  |  | 0d |  | 8/5 M-F w/JLAB Holidays ReBaseline |  |  |  |  |  |  | 0 | FENKER H | 1 | 1 | 07-034 | Z | HOWARD F | 08-048 | 09-022 |  | 10-069 | 11-026 | 13-006 |  |  | 4314 |  | 10-076 | 11-017 | 11-046 | 12-012 | 12-036 |  |  |  |  |  |  |  |  |  |  | 08-052 |  | NO RESOURCES | 24314030a | Y |  |  | PR |  | 13-015 |  |  |  |  |  |  |
| 24314040 |  | Dipole Drawing Validation |  | 89d | 2015-05-19 | 2015-09-24 | 2-29M, 24314048 |  |  |  |  | 62d | 0d | 8/5 M-F w/JLAB Holidays ReBaseline | MECH DES [480 h] | 24,624 |  |  |  |  | 0 | FENKER H | 1 | 1 | 07-034 | S | HOWARD F | 08-048 | 09-022 | 10-008 | 10-069 | 11-026 | 13-006 |  |  | 4314 |  | 10-076 |  |  |  | 12-036 |  |  |  |  | ST |  |  |  |  |  |  |  |  | 24314040 |  |  |  | PR |  | 13-015 |  | PE |  | 14-001 |  | Pat |
| 24314050M |  | Dipole Ready for Installation | milestone | 0d | 2015-05-19 | 2015-05-19 | 2-29M |  |  |  |  | 0d |  | 8/5 M-F w/JLAB Holidays ReBaseline |  |  |  |  |  |  | 0 | FENKER H | 1 | 1 | 07-034 | M | HOWARD F | 08-048 | 09-022 |  | 10-069 |  | 13-006 |  |  |  | 09-012 | 10-076 | 11-017 | 11-046 | 12-012 | 12-036 |  |  |  |  |  |  |  |  |  |  |  |  |  | 24314050M |  |  |  | PR |  | 13-015 |  |  |  |  |  |  |
| 24314035a |  | Dipole HC Test |  | 5d | 2015-08-26 | 2015-09-01 | 28236005 FS-5d, 28236000, 24368305 |  |  |  |  | 0d |  | 8/5 M-F w/JLAB Holidays ReBaseline | MECH TECH [40 h]; MECH ENG [80 h] | 7,866.4 |  |  |  |  | 0 | FENKER H | 1 | 1 | 07-034 | H | HOWARD F | 08-048 | 09-022 |  | 10-069 | 11-026 | 13-006 |  |  | 4314 | 09-012 | 10-076 |  | 11-046 | 12-012 | 12-036 |  |  |  |  |  |  |  |  |  |  | 08-052 |  |  | 24314035a |  |  |  | PR |  | 13-015 |  | PE |  | 14-001 | 12-054 |  |
| 24314051M |  | Dipole Contract Complete | milestone | 0d | 2015-09-25 | 2015-09-25 | 24314040, 24314049 |  |  |  |  | 62d |  | 8/5 M-F w/JLAB Holidays ReBaseline |  |  |  |  |  |  | 0 | FENKER H | 1 | 1 | 07-034 | M | HOWARD F | 08-048 | 09-022 |  | 10-069 |  | 13-006 |  |  |  | 09-012 | 10-076 | 11-017 | 11-046 | 12-012 | 12-036 |  |  |  |  |  |  |  |  |  |  |  |  |  | 24314051M |  |  |  | PR |  | 13-015 |  |  |  |  |  |  |

Notes:
- 14314010: Corrective Actions: 07 Mar 2007, Added This Activity to / Match Fy08-15 Master Schedule. PMC / Steps: Magnet Traveler (manufacturing plan) Complete (done); Turntable Delivered (done); Taping Machine Delivered (done); Conductor Tractors & Guides Delivered (done); Clamps & Hand Tools Delivered (done); Dipole Mandrel Delivered (done)
- 14314012: Steps: Stress Analysis complete (D-8) (done); Quench Protection Analysis (D-10) (done); DC System Analysis complete (D-12) (done); Instrumentation design (D-13) (done); Analysis of Pressure Vessels (C-1) (done); Vessel weld design & analysis (C-4) (done); 100% Drawing package (D-15) (done); Final Design Review (D-4) (done)
- 14314045: Corrective Actions: 07 Mar 2007, Added This Activity to Match Fy08-15 Master / Schedule. PMC
- 24314012: Explanation: Vendor invoiced 50% and Howard Accrued / 50% 11/4/2013
- 24314040: Steps: 1st 25% of vendor-supplied drawings checked; 2nd 25% of vendor-supplied drawings checked; 3rd 25% of vendor-supplied drawings checked; 4th 25% of vendor-supplied drawings checked

| ID | WBS | Activity | Type | Duration | Start | Finish | Predecessors | Complete | Planned start | Planned finish | Resources | Cost | Actual cost | Calculated Remaining Total Cost | MONTHLY EV COST | RESP - Responsibility | STRT%COMP for CM EVM | FNSH%COMP for CM EVM | CR 07-034 | EVMS Reporting Codes | CAM RESPONSIBLE | CR 08-048 | CR 08-059 | CR 10-069 | CR 11-026 | CR 13-006 | CR 10-008 | CR 11-017 | CR 11-025 | CR 11-046 | CR 12-012 | CR 12-036 | LOE Divider | LOE Multiplier | CR 09-022 | Activities with Steps | CR 10-001 | CR 10-063 | Inter Project Link (IPL) | CR 10-075 | CR 12-003 | CR 12-054 | Remaining Material Cost Based on % Compl | Claimed Material Cost Based on % Complet | Initial Claimed Material Calc | Claimed Material Divider | 12 GEV MAJOR PROCUREMENT CATAGORY | CR 10-022 | CR 08-052 | CR 10-057 | CR 10-052 | Phil Dev | MARCH!!! | LOE % Pre Calc | LOE % | Specification | CR 12-055 | CR 12-001 | CR 10-076 | CR 12-023 | CR 12-022 | CR 12-053 |
| --- | --- | --- | --- | --- | --- | --- | --- | --- | --- | --- | --- | --- | --- | --- | --- | --- | --- | --- | --- | --- | --- | --- | --- | --- | --- | --- | --- | --- | --- | --- | --- | --- | --- | --- | --- | --- | --- | --- | --- | --- | --- | --- | --- | --- | --- | --- | --- | --- | --- | --- | --- | --- | --- | --- | --- | --- | --- | --- | --- | --- | --- | --- |
|  | 5 | **1.4.3.1.5 MAGNET COMPONENTS PROCURED BY JLAB** |  |  | 2009-01-02 | 2014-08-27 |  |  |  |  |  |  |  |  |  |  |  |  |  |  |  |  |  |  |  |  |  |  |  |  |  |  |  |  |  |  |  |  |  |  |  |  |  |  |  |  |  |  |  |  |  |  |  |  |  |  |  |  |  |  |  |  |
| 14315010 |  | Design Superconductor for Q2/3 and Dipole |  | 79d | 2009-01-02 A | 2009-04-24 A | 9-090M FS+59d | 100% |  |  | MECH ENG [140 h]; MECH DES [72 h] | 12,089.88 | 12,089.88 | 0 | 12089.88 | FENKER H | 1 | 1 | 07-034 | H | HOWARD F | 08-048 | 08-059 | 10-069 | 11-026 | 13-006F |  |  |  |  |  |  |  |  |  |  |  |  |  |  |  |  |  |  |  |  |  |  |  |  |  |  |  |  |  |  |  |  |  |  |  |  |
| 14315012 |  | Bidding Process Superconductor for Q2/3 and Dipole |  | 104d | 2009-04-21 A | 2009-09-16 A | 9-090M FS+169d | 100% |  |  |  |  |  |  | 0 | FENKER H | 1 | 1 | 07-034 | Z | HOWARD F | 08-048 |  | 10-069 | 11-026 |  | 10-008 | 11-017 | 11-025 | 11-046 | 12-012 | 12-036F |  |  |  |  |  |  |  |  |  |  |  |  |  |  |  |  |  |  |  |  |  |  |  |  |  |  |  |  |  |  |
| 14315050LOE |  | Procurement Oversight |  | 106d | 2009-05-01 A | 2009-09-30 A | 9-090M FS+142d, 14315010 FS-20d | 100% |  |  | TRAVEL; MECH ENG [240 h]; MECH DES [80 h] | 25,070.48 | 18,821.6 | 0 | 25070.48 | FENKER H | 1 | 1 | 07-034 | E | HOWARD F | 08-048 |  | 10-069 | 11-026 | 13-006F |  |  |  |  |  |  | 100 | 100 | 09-022 |  |  |  |  |  |  |  |  |  |  |  |  |  |  |  |  |  |  |  |  |  |  |  |  |  |  |  |
| 14315030 |  | Design Instruments & Controls for All Mag FY09 |  | 431.54d | 2009-05-29 A | 2011-02-28 A | 9-090M FS+185d | 100% |  |  | MECH DES [121.42 h]; MECH ENG [229.09 h] | 20,596.87 | 20,596.87 | 0 | 19941.2857 | FENKER H | 1 | 1 | 07-034 | S | HOWARD F | 08-048 |  | 10-069 | 11-026 |  |  |  |  |  | 12-012 | 12-036F |  |  | 09-022 | ST | 10-001B | 10-063 |  |  |  |  |  |  |  |  |  |  |  |  |  |  |  |  |  |  |  |  |  |  |  |  |
| 14315000 |  | Design DC Pwr Sys for All Mag (IPL) |  | 124d | 2009-06-01 A | 2009-11-23 A | 9-100M | 100% |  |  | MECH DES [120 h]; MECH ENG [220 h] | 19,488.02 | 19,488.02 | 0 | 19915.8 | FENKER H | 1 | 1 | 07-034 | H | HOWARD F | 08-048 |  | 10-069 | 11-026 | 13-006 | 10-008 |  |  | 11-046 | 12-012 | 12-036F |  |  | 09-022 |  |  |  | IPL | 10-075 | 12-003 | 12-054F |  |  |  |  |  |  |  |  |  |  |  |  |  |  |  |  |  |  |  |  |
| 14315022 |  | Bidding Process Cryo Reservoirs for All Mag |  | 114d | 2009-06-15 A | 2009-11-23 A | 14315050x FS+37d | 100% |  |  |  |  |  |  | 0 | FENKER H | 1 | 1 | 07-034 | Z | HOWARD F | 08-048 |  | 10-069 | 11-026 |  |  | 11-017 |  |  | 12-012 | 12-036F |  |  | 09-022 |  |  |  |  |  |  |  |  |  |  |  |  |  |  |  |  |  |  |  |  |  |  |  |  |  |  |  |
| 14315030b |  | Design Instruments & Controls for All Mag FY10 |  | 346d | 2009-09-30 A | 2011-02-28 A | 14315030 FS-400d | 100% |  |  | MECH ENG [570.91 h]; MECH DES [302.58 h] | 51,736.82 | 51,736.82 | 0 | 51283.1427 | FENKER H | 1 | 1 |  | S | HOWARD F |  |  | 10-069 | 11-026 |  |  |  |  |  | 12-012 | 12-036F |  |  |  | ST | 10-001B | 10-063 |  |  |  |  |  |  |  |  |  |  |  |  |  |  |  |  |  |  |  |  |  |  |  |  |
| 14315050LOEb |  | Procurement Oversight |  | 248d | 2009-10-01 A | 2010-09-30 A | 14315050LOE | 100% |  |  | TRAVEL; MECH ENG [240 h]; MECH DES [80 h] | 25,871.42 | 19,423.2 | 0 | 25871.419272 | FENKER H | 1 | 1 | 07-034 | E | HOWARD F | 08-048 |  | 10-069 | 11-026 | 13-006F |  |  |  |  |  |  | 100 | 100 | 09-022 |  |  |  |  |  |  |  |  |  |  |  |  |  |  |  |  |  |  |  |  |  |  |  |  |  |  |  |
| 14315002 |  | Bidding Process DC Pwr Sys for HB & Q1 Mag |  | 145d | 2009-12-21 A | 2010-07-23 A | 14315000 | 100% | 2009-12-28 | 2010-07-23 |  |  |  |  | 0 | FENKER H | 1 | 1 | 07-034 | Z | HOWARD F | 08-048 |  | 10-069 | 11-026 |  | 10-008 |  |  | 11-046 | 12-012 | 12-036F |  |  | 09-022 | NB |  |  |  | 10-075 | 12-003 | 12-054F |  |  |  |  |  |  |  |  |  |  |  |  |  |  |  |  |  |  |  |  |
| 14315003 |  | Bidding Process DC Pwr Sys forQ2/Q3/Dipole Mag |  | 145d | 2009-12-21 A | 2010-07-23 A | 14315000 | 100% | 2009-12-28 | 2010-07-23 |  |  |  |  | 0 | FENKER H | 1 | 1 | 07-034 | Z | HOWARD F | 08-048 |  | 10-069 | 11-026 |  | 10-008 |  |  | 11-046 | 12-012 | 12-036F |  |  | 09-022 | NB |  |  |  | 10-075 | 12-003 | 12-054F |  |  |  |  |  |  |  |  |  |  |  |  |  |  |  |  |  |  |  |  |
| 14315025 |  | Vend Fab Cryo Reservoirs Receipt of Materials less Electric Cylinders and LVDTs |  | 19d | 2010-01-04 A | 2010-01-29 A | 14315022, 9-100M FS+59d | 100% |  |  | PROCUREMENT<$50K 60 NO ESCALATION; PROCUREMENT>$50K 69 NO ESCALATION | 242,300 |  | 0 | 242300 | FENKER H | 1 | 1 | 07-034 | P | HOWARD F | 08-048 |  | 10-069 | 11-026 |  |  | 11-017 |  |  | 12-012 | 12-036F |  |  | 09-022 |  |  |  |  |  |  |  | 0 | 242300 | 24230000 | 100 | 4315 | 10-022 |  |  |  |  |  |  |  |  |  |  |  |  |  |  |
| 14315026 |  | Vend Fab Cryo Reservoirs Receipt of Electric Cylinders and LVDTs |  | 59d | 2010-01-04 A | 2010-03-29 A | 14315025 FS-19d | 100% |  |  | PROCUREMENT>$50K 69 NO ESCALATION | 134,500 |  | 0 | 134500 | FENKER H | 1 | 1 | 07-034 | P | HOWARD F | 08-048 |  | 10-069 | 11-026 |  |  | 11-017 |  |  | 12-012 | 12-036F |  |  | 09-022 |  |  |  |  |  |  |  | 0 | 134500 | 13450000 | 100 | 4315 | 10-022 |  |  |  |  |  |  |  |  |  |  |  |  |  |  |
| 14315027 |  | Vend Fab Cryo Reservoirs CCR#2 & 3 JT Valves and Bayonets Complete |  | 104d | 2010-01-04 A | 2010-06-01 A | 14315055 FS-125d, 14315026 FS-61d | 100% |  |  | PROCUREMENT>$50K 69 NO ESCALATION | 52,000 |  | 0 | 52000 | FENKER H | 1 | 1 | 07-034 | P | HOWARD F | 08-048 |  | 10-069 | 11-026 |  |  | 11-017 |  |  | 12-012 | 12-036F |  |  | 09-022 |  |  |  |  |  |  |  | 0 | 52000 | 5200000 | 100 | 4315 | 10-022 |  |  |  |  |  |  |  |  |  |  |  |  |  |  |
| 14315027A |  | Vend Fab Cryo Reservoirs CCR#2 & 3 Complete |  | 262d | 2010-01-04 A | 2011-01-24 A | 14315027 FS-168d | 100% |  |  | PROCUREMENT>$50K 69 NO ESCALATION | 42,000 |  | 0 | 42000 | FENKER H | 1 | 1 |  | P | HOWARD F |  |  | 10-069 | 11-026 |  |  | 11-017 |  |  | 12-012 | 12-036F |  |  |  |  |  |  |  |  |  |  | 0 | 42000 | 4200000 | 100 | 4315 | 10-022 |  |  |  |  |  |  |  |  |  |  |  |  |  |  |
| 14315027B |  | Vend Fab Cryo Reservoirs CCR#2 & 3 Approved Acceptance Test/Shipment |  | 286d | 2010-01-04 A | 2011-02-28 A | 14315027A FS-247d | 100% |  |  | PROCUREMENT>$50K 69 NO ESCALATION | 69,100 |  | 0 | 69100 | FENKER H | 1 | 1 |  | P | HOWARD F |  |  | 10-069 | 11-026 |  |  | 11-017 |  |  | 12-012 | 12-036F |  |  |  |  |  |  |  |  |  |  | 0 | 69100 | 6910000 | 100 | 4315 | 10-022 |  |  |  |  |  |  |  |  |  |  |  |  |  |  |
| 14315027C |  | Vend Fab Cryo Reservoirs CCR#1 Test and Fabrication Documentation |  | 286d | 2010-01-04 A | 2011-02-28 A | 14315027B FS-267d | 100% |  |  | PROCUREMENT>$50K 69 NO ESCALATION | 28,000 |  | 0 | 28000 | FENKER H | 1 | 1 |  | P | HOWARD F |  |  | 10-069 | 11-026 |  |  | 11-017 |  |  | 12-012 | 12-036F |  |  |  |  |  |  |  |  |  |  | 0 | 28000 | 2800000 | 100 | 4315 | 10-022 |  |  |  |  |  |  |  |  |  |  |  |  |  |  |
| 14315027D |  | Vend Fab Cryo Reservoirs CCR#4 5 & 6 JT Valves and Bayonets Complete |  | 104d | 2010-01-04 A | 2010-06-01 A | 14315027C FS-286d | 100% |  |  | PROCUREMENT>$50K 69 NO ESCALATION | 78,000 |  | 0 | 78000 | FENKER H | 1 | 1 |  | P | HOWARD F |  |  | 10-069 | 11-026 |  |  | 11-017 |  |  | 12-012 | 12-036F |  |  |  |  |  |  |  |  |  |  | 0 | 78000 | 7800000 | 100 | 4315 | 10-022 |  |  |  |  |  |  |  |  |  |  |  |  |  |  |
| 14315027F |  | Vend Fab Cryo Reservoirs CCR#4 5 & 6 Complete |  | 491d | 2010-01-04 A | 2011-12-19 A | 14315027D FS-168d | 100% |  |  | PROCUREMENT>$50K 69 NO ESCALATION | 63,000 |  | 0 | 63000 | FENKER H | 1 | 1 |  | P | HOWARD F |  |  | 10-069 | 11-026 |  |  | 11-017 |  |  | 12-012 | 12-036F |  |  |  |  |  |  |  |  |  |  | 0 | 63000 | 6300000 | 100 | 4315 | 10-022 |  |  |  |  |  |  |  |  |  |  |  |  |  |  |
| 14315027G |  | Vend Fab Cryo Reservoirs CCR#4 5 & 6 Approved Acceptance Test/Shipment |  | 513d | 2010-01-04 A | 2012-01-27 A | 14315027F FS-458d | 100% |  |  | PROCUREMENT>$50K 69 NO ESCALATION | 101,900 |  | 0 | 101900 | FENKER H | 1 | 1 |  | P | HOWARD F |  |  | 10-069 | 11-026 |  |  | 11-017 |  |  | 12-012 | 12-036F |  |  |  |  |  |  |  |  |  |  | 0 | 101900 | 10190000 | 100 | 4315 | 10-022 |  |  |  |  |  |  |  |  |  |  |  |  |  |  |
| 14315027H |  | Vend Fab Cryo Reservoirs CCR#4 5 & 6 Test and Fabrication Documentation |  | 528d | 2010-01-04 A | 2012-02-20 A | 14315027G FS-494d | 100% | 2010-01-04 | 2012-02-17 | PROCUREMENT>$50K 69 NO ESCALATION | 42,100 |  | 0 | 42100 | FENKER H | 1 | 1 |  | P | HOWARD F |  |  | 10-069 | 11-026 |  |  | 11-017 |  |  | 12-012 | 12-036F |  |  |  |  |  |  |  |  |  |  | 0 | 42100 | 4210000 | 100 | 4315 | 10-022 |  |  |  |  |  |  |  |  |  |  |  |  |  |  |
| 14315032 |  | Bidding Process Instruments & Controls for All Mag |  | 1d | 2010-03-01 A | 2010-03-01 A | 14315030b FS-30d | 100% |  |  |  |  |  |  | 0 | FENKER H | 1 | 1 | 07-034 | Z | HOWARD F | 08-048 |  | 10-069 | 11-026 |  |  |  |  |  | 12-012 | 12-036F |  |  | 09-022 |  |  | 10-063 |  |  |  |  |  |  |  |  |  |  |  |  |  |  |  |  |  |  |  |  |  |  |  |  |
| 14315035 |  | Proc Instruments & Controls for HB and Q1 magnets |  | 292d | 2010-03-01 A | 2011-04-29 A | 14315032 FS-70d | 100% |  |  | PROCUREMENT>$50K 69 NO ESCALATION FY11; PROCUREMENT<$50K 60 NO ESCALATION FY11 | 343,919.79 |  | 0 | 343919.79433 | FENKER H | 1 | 1 | 07-034 | D | HOWARD F | 08-048 |  | 10-069 | 11-026 |  |  |  |  |  | 12-012 | 12-036F |  |  | 09-022 |  |  | 10-063 |  |  |  |  | 0 | 343919.79433 | 34391979.433 | 100 | 4315 |  | 08-052 |  |  |  |  |  |  |  |  |  |  |  |  |  |
| 14315015 |  | Procure and Extrude Copper Stabilizer |  | 228d | 2010-04-26 A | 2011-03-28 A | 14315012, 14314000M5 FS-64d | 100% |  |  | PROCUREMENT<$50K 60 NO ESCALATION FY11; PROCUREMENT>$50K 69 NO ESCALATION FY11 | 214,142.24 |  | 0 | 214142.24 | FENKER H | 1 | 1 | 07-034 | D | HOWARD F | 08-048 |  | 10-069 | 11-026 |  | 10-008 | 11-017 | 11-025 | 11-046 | 12-012 | 12-036F |  |  |  |  |  |  |  |  |  |  | 0 | 214142.24 | 21414224 | 100 | 4315 |  |  | 10-057 |  |  |  |  |  |  |  |  |  |  |  |  |
| 14315038 |  | Assemble & Test Instruments & Controls Phase 1 (FY10) |  | 107d | 2010-04-26 A | 2010-09-24 A | 14315035 FS-160d | 100% |  |  | MECH ENG [520 h]; ELEC TECH [800 h] | 67,402 | 67,402 | 0 | 69550 | FENKER H | 1 | 1 | 07-034 | U | HOWARD F | 08-048 |  | 10-069 | 11-026 |  |  |  |  |  | 12-012 | 12-036F |  |  | 09-022 |  |  | 10-063 |  |  |  |  |  |  |  |  |  |  |  |  |  |  |  |  |  |  |  |  |  |  |  |  |
| 14315055 |  | Procure Burnout Resistant Current Leads |  | 1d | 2010-05-24 A | 2010-05-24 A | 9-100M FS+142d | 100% |  |  | PROCUREMENT<$50K 60; PROCUREMENT>$50K 69 | 95,500 |  | 0 | 95500 | FENKER H | 1 | 1 |  | P | HOWARD F |  |  | 10-069 | 11-026 |  |  | 11-017 |  |  | 12-012 | 12-036F |  |  |  |  |  |  |  |  |  |  | 0 | 95500 | 9550000 | 100 |  |  |  |  | 10-052 |  |  |  |  |  |  |  |  |  |  |  |
| 14315015A |  | Solder SC Cable to Extrusion |  | 382d | 2010-09-13 A | 2012-03-30 A | 14315015 FS-75d | 100% |  |  | PROCUREMENT<$50K 60 NO ESCALATION FY11; PROCUREMENT>$50K 69 NO ESCALATION FY11 | 181,696 |  | 0 | 181696 | FENKER H | 1 | 1 |  | D | HOWARD F |  |  | 10-069 | 11-026 |  |  | 11-017 | 11-025 | 11-046 | 12-012 | 12-036F |  |  |  |  |  |  |  |  |  |  | 0 | 181696 | 18169600 | 100 | 4315 |  |  | 10-057 |  |  |  |  |  |  |  |  |  |  |  |  |
| 14315027J |  | Vend Fab Cryo Reservoirs CCR#4 5 & 6 Vendor Change Order |  | 1d | 2010-09-20 A | 2010-09-20 A | 14315027D | 100% |  |  | PROCUREMENT>$50K 69 NO ESCALATION | 21,000 |  | 0 | 21000 | FENKER H | 1 | 1 |  | P | HOWARD F |  |  | 10-069 | 11-026 |  |  | 11-017 |  |  | 12-012 | 12-036F |  |  |  |  |  |  |  |  |  |  | 0 | 21000 | 2100000 | 100 | 4315 | 10-022 |  |  |  |  |  |  |  |  |  |  |  |  |  |  |
| 14315060 |  | Vend Fab DCPS - Peg Point #1 Design & Approval |  | 97d | 2010-09-30 A | 2011-02-25 A | 14315003 FS-58d, 14315002 FS-58d | 100% |  |  | PROCUREMENT<$50K 60 NO ESCALATION; PROCUREMENT>$50K 69 NO ESCALATION | 225,000 |  | 0 | 225000 | FENKER H | 1 | 1 |  | D | HOWARD F |  |  |  | 11-026 |  |  |  |  | 11-046 | 12-012 | 12-036F |  |  |  |  |  |  |  | 10-075 | 12-003 | 12-054F | 0 | 225000 | 22500000 | 100 |  |  |  |  |  |  |  |  |  |  |  |  |  |  |  |  |
| 14315065 |  | Vend Fab DCPS - Peg Point #2 Materials in-house to start prod: Items 1&2 |  | 216d | 2010-09-30 A | 2011-08-15 A | 14315060 FS-98d | 100% |  |  | PROCUREMENT>$50K 69 NO ESCALATION | 159,000 |  | 0 | 159000 | FENKER H | 1 | 1 |  | D | HOWARD F |  |  |  | 11-026 |  |  |  |  | 11-046 | 12-012 | 12-036F |  |  |  |  |  |  |  | 10-075 | 12-003 | 12-054F | 0 | 159000 | 15900000 | 100 |  |  |  |  |  |  |  |  |  |  |  |  |  |  |  |  |
| 14315070 |  | Vend Fab DCPS - Peg Point #3 Materials in-house to start prod: Items 3,4,&5 |  | 327d | 2010-09-30 A | 2012-01-31 A | 14315065 FS-142d | 100% |  |  | PROCUREMENT>$50K 69 NO ESCALATION | 245,000 |  | 0 | 245000 | FENKER H | 1 | 1 |  | D | HOWARD F |  |  |  | 11-026 |  |  |  |  | 11-046 | 12-012 | 12-036F |  |  |  |  |  |  |  | 10-075 | 12-003 | 12-054F | 0 | 245000 | 24500000 | 100 |  |  |  |  |  |  |  |  |  |  |  |  |  |  |  |  |
| 14315075 |  | Vend Fab DCPS - Peg Point #4 Shipment of Items 1&2 |  | 572d | 2010-09-30 A | 2012-12-17 A | 14315070 FS-290d | 100% | 2010-09-30 | 2013-01-25 | PROCUREMENT>$50K 69 NO ESCALATION | 77,000 |  | 0 | 77000 | FENKER H | 1 | 1 |  | D | HOWARD F |  |  |  | 11-026 |  |  |  |  | 11-046 | 12-012 | 12-036F |  |  |  |  |  |  |  | 10-075 | 12-003 | 12-054F | 0 | 77000 | 7700000 | 100 |  |  |  |  |  | MP |  |  |  |  |  |  |  |  |  |  |
| 14315080 |  | Vend Fab DCPS - Peg Point #5 Arrival Test of Items 1&2 |  | 638d | 2010-09-30 A | 2013-08-30 A | 14315075 FS-347d | 100% | 2010-09-30 | 2013-04-30 | PROCUREMENT>$50K 69 NO ESCALATION | 28,000 |  | 28000 | 28000 | FENKER H | 1 | 1 |  | D | HOWARD F |  |  |  | 11-026 |  |  |  |  | 11-046 | 12-012 | 12-036F |  |  |  |  |  |  |  | 10-075 | 12-003 | 12-054F | 0 | 28000 | 2800000 | 100 |  |  |  |  |  | MP |  |  |  |  |  |  |  |  |  |  |
| 14315085 |  | Vend Fab DCPS - Peg Point #6 Shipment of Items 3,4,&5 |  | 594d | 2010-09-30 A | 2013-05-10 A | 14315080 FS-412d | 100% | 2010-09-30 | 2013-02-27 | PROCUREMENT>$50K 69 NO ESCALATION | 117,000 |  | 0 | 117000 | FENKER H | 1 | 1 |  | D | HOWARD F |  |  |  | 11-026 |  |  |  |  | 11-046 | 12-012 | 12-036F |  |  |  |  |  |  |  | 10-075 | 12-003 | 12-054F | 0 | 117000 | 11700000 | 100 |  |  |  |  |  | MP | XX |  |  |  |  |  |  |  |  |  |
| 14315090 |  | Vend Fab DCPS - Peg Point #7 Arrival Test of Items 3,4,&5 |  | 659d | 2010-09-30 A | 2013-08-30 A | 14315085 FS-518d | 100% | 2010-09-30 | 2013-05-30 | PROCUREMENT>$50K 69 NO ESCALATION | 53,320 |  | 53320 | 53320 | FENKER H | 1 | 1 |  | D | HOWARD F |  |  |  | 11-026 |  |  |  |  |  |  |  |  |  |  |  |  |  |  | 10-075 |  |  | 0 | 53320 | 5332000 | 100 |  |  |  |  |  | MP |  |  |  |  |  |  |  |  |  |  |
| 14315095 |  | Vend Fab DCPS - Peg Point #8 Delivery of Spare Parts & Maintenance Inventory |  | 659d | 2010-09-30 A | 2013-05-10 A | 14315090 FS-616d | 100% | 2010-09-30 | 2013-05-30 | PROCUREMENT>$50K 69 NO ESCALATION | 17,762 |  | 0 | 17762 | FENKER H | 1 | 1 |  | D | HOWARD F |  |  |  | 11-026 |  |  |  |  |  |  |  |  |  |  |  |  |  |  | 10-075 |  |  | 0 | 17762 | 1776200 | 100 |  |  |  |  |  |  |  |  |  |  |  |  |  |  |  |  |
| 14315050LOEc |  | Procurement Oversight |  | 247d | 2010-10-01 A | 2011-09-29 A | 14315050LOEb | 100% |  |  | MECH DES [80 h]; TRAVEL; MECH ENG [240 h] | 26,696.32 | 20,042.4 | 0 | 26696.32 | FENKER H | 1 | 1 | 07-034 | E | HOWARD F | 08-048 |  | 10-069 | 11-026 | 13-006F |  |  |  |  |  |  | 100 | 100 | 09-022 |  |  |  |  |  |  |  |  |  |  |  |  |  |  |  |  |  |  | 8.09716599 | 91.902834 |  |  |  |  |  |  |  |
| 14315037a |  | Assemble & Test Instruments & Controls Phase 2 (FY11) |  | 589d | 2010-11-01 A | 2013-06-17 A | 14315038 | 100% | 2010-11-01 | 2013-03-22 | ELEC TECH [800 h]; MECH ENG [520 h] | 71,359.86 | 71,609.41 | 0 | 69550 | FENKER H | 1 | 1 | 07-034 | S | HOWARD F | 08-048 |  | 10-069 | 11-026 |  |  |  |  |  | 12-012 | 12-036F |  |  | 09-022 | ST |  | 10-063 |  |  |  |  |  |  |  |  |  |  |  |  |  |  |  |  |  | 14315037a |  |  |  |  |  |  |
| 14315042 |  | Bidding Process Iron Yoke for Q2/3 and Dipole |  | 252d | 2011-01-03 A | 2012-01-09 A | 9-110M FS+30d, 14315055x | 100% | 2011-01-04 | 2012-01-09 |  |  |  |  | 0 | FENKER H | 1 | 1 | 07-034 | Z | HOWARD F | 08-048 |  | 10-069 | 11-026 | 13-006F |  |  |  | 11-046 | 12-012 | 12-036F |  |  |  |  |  |  |  |  |  |  |  |  |  |  |  |  |  |  |  |  |  |  |  |  |  |  |  |  |  |  |
| 14315016 |  | Inspect & Ship Superconductor for Q2/3 and Dipole to ReRolling Facility |  | 201d | 2011-02-01 A | 2011-11-14 A | 14315015Ba FS-215d, 14315015B FS-115d | 100% |  |  | SUPPLIES & MATERIALS; MECH ENG [200 h]; MECH DES [240 h] | 37,387.48 | 24,915.29 | 0 | 37265.39 | FENKER H | 1 | 1 | 07-034 | H | HOWARD F | 08-048 |  | 10-069 | 11-026 |  | 10-008 | 11-017 | 11-025 | 11-046 | 12-012 | 12-036F |  |  |  |  |  |  |  |  |  |  |  |  |  |  |  |  |  |  |  |  |  |  |  |  |  |  |  |  |  |  |
| 14315028 |  | Inspect & Ship Cryo Reservoirs for HB & Q1 magnets |  | 547d | 2011-02-01 A | 2013-07-15 A | 14315025, 14315027B | 100% | 2011-02-01 | 2013-04-12 | MECH TECH [320 h]; MECH DES [160 h]; SUPPLIES & MATERIALS; MECH ENG [360 h] | 56,146.96 | 47,244.09 | 0 | 54783.89 | FENKER H | 1 | 1 | 07-034 | D | HOWARD F | 08-048 |  | 10-069 | 11-026 |  |  |  |  | 11-046 | 12-012 | 12-036F |  |  | 09-022 |  |  | 10-063 |  |  | 12-003 |  |  |  |  |  |  | 10-022 |  |  |  |  |  |  |  | 14315028 |  |  |  |  |  |  |
| 14315018 |  | ReRoll Superconductor Prototype Run |  | 140d | 2011-06-01 A | 2011-12-19 A | 14315016 FS-60d | 100% |  |  | PROCUREMENT<$50K 60 | 15,000 |  | 0 | 15000 | FENKER H | 1 | 1 | 07-034 | H | HOWARD F | 08-048 |  | 10-069 | 11-026 |  | 10-008 | 11-017 | 11-025 | 11-046 | 12-012 | 12-036F |  |  |  |  |  |  |  |  |  |  | 0 | 15000 | 1500000 | 100 |  |  |  |  |  |  |  |  |  |  |  |  |  |  |  |  |
| 14315015A5 |  | Completion of Solder SC Cable to Extrusion Part A |  | 322d | 2011-07-01 A | 2012-10-15 A | 14315015A FS-88d | 100% |  |  | PROCUREMENT<$50K 60; PROCUREMENT>$50K 69 | 92,000 |  | 0 | 92000 | FENKER H | 1 | 1 |  | D | HOWARD F |  |  | 10-069 | 11-026 |  |  | 11-017 | 11-025 | 11-046 | 12-012 | 12-036F |  |  |  |  |  |  |  |  |  |  | 0 | 92000 | 9200000 | 100 | 4315 |  |  | 10-057 |  |  |  |  |  |  | 12-055 |  |  |  |  |  |
| 14315050LOEd |  | Procurement Oversight FY11 |  | 1d | 2011-10-03 A | 2011-10-03 A | 14315050LOEc | 100% |  |  | TRAVEL; MECH ENG [0.97 h]; MECH DES [0.32 h] | 110.37 | 83.43 | 0 | 107.7891 | FENKER H | 1 | 1 | 07-034 | E | HOWARD F | 08-048 |  | 10-069 | 11-026 | 13-006F |  |  |  |  |  |  | 100 | 100 | 09-022 |  |  |  |  |  |  |  |  |  |  |  |  |  |  |  |  |  |  | 100 | 0 |  |  | 12-001 |  |  |  |  |
| 14315050LOEf |  | Procurement Oversight FY12 |  | 246d | 2011-10-03 A | 2012-09-27 A | 14315050LOEd | 100% |  |  | TRAVEL; MECH ENG [239.03 h]; MECH DES [79.68 h] | 27,437.35 | 20,598.97 | 0 | 27437.3492 | FENKER H | 1 | 1 | 07-034 | E | HOWARD F | 08-048 |  | 10-069 | 11-026 | 13-006F |  |  |  |  |  |  | 100 | 100 | 09-022 |  |  |  |  |  |  |  |  |  |  |  |  |  |  |  |  |  |  | 7.31707317 | 92.68292682 |  |  | 12-001 |  |  |  |  |
| 14315019 |  | ReDraw Superconductor Production Run |  | 32d | 2012-01-03 A | 2012-02-16 A | 9-120M FS+59d, 14315018 | 100% |  |  | PROCUREMENT<$50K 60; PROCUREMENT>$50K 69; TRAVEL; MECH ENG [40 h] | 106,204.8 | 2,804.8 | 0 | 106204.8 | FENKER H | 1 | 1 | 07-034 | D | HOWARD F | 08-048 |  | 10-069 | 11-026 |  | 10-008 | 11-017 | 11-025 | 11-046 | 12-012 | 12-036F |  |  |  |  |  |  |  |  |  |  | 0 | 100000 | 10000000 | 100 |  |  |  |  |  |  |  |  |  |  |  |  | 10-076 |  |  |  |
| 14315045 |  | Vend Fab Yoke Steel Planning for Dipole, Q2, Q3 Delivered & Accepted |  | 55d | 2012-01-12 A | 2012-03-30 A | 9-120M FS+65d, 14315042 | 100% |  |  | PROCUREMENT<$50K 60 NO ESCALATION | 10,000 |  | 0 | 10000 | FENKER H | 1 | 1 |  | P | HOWARD F |  |  |  |  | 13-006F |  |  |  |  |  | 12-036F |  |  |  |  |  |  |  |  |  |  | 0 | 10000 | 1000000 | 100 | 4315 |  |  |  |  |  |  |  |  |  |  |  |  | 12-023 |  |  |
| 14315045A |  | Vend Fab Yoke Steel Receipt of Steel Material Inspected |  | 98d | 2012-01-12 A | 2012-05-31 A | 14315045 FS-55d | 100% |  |  | PROCUREMENT<$50K 60 NO ESCALATION; PROCUREMENT>$50K 69 NO ESCALATION | 262,000 |  | 0 | 262000 | FENKER H | 1 | 1 |  | P | HOWARD F |  |  |  |  | 13-006F |  |  |  |  |  | 12-036F |  |  |  |  |  |  |  |  |  |  | 0 | 262000 | 26200000 | 100 | 4315 |  |  |  |  |  |  |  |  |  |  |  |  | 12-023 |  |  |
| 14315045B |  | Vend Fab Yoke Steel 1st Article: 1st Dipole/Yoke/Casting Inspt/Accept |  | 86d | 2012-01-12 A | 2012-05-14 A | 14315045A FS-98d | 100% |  |  | PROCUREMENT>$50K 69 NO ESCALATION | 150,000 |  | 0 | 150000 | FENKER H | 1 | 1 |  | P | HOWARD F |  |  |  |  | 13-006F |  |  |  |  |  | 12-036F |  |  |  |  |  |  |  |  |  |  | 0 | 150000 | 15000000 | 100 | 4315 |  |  |  |  |  |  |  |  |  |  |  |  | 12-023 |  |  |
| 14315045C |  | Vend Fab Yoke Steel SHMS Dipole Casting/ Annealing Comp. Casting Delv/Accept |  | 154d | 2012-01-12 A | 2012-08-20 A | 14315045B FS-118d | 100% |  |  | PROCUREMENT>$50K 69 NO ESCALATION | 558,000 |  | 0 | 558000 | FENKER H | 1 | 1 |  | P | HOWARD F |  |  |  |  |  |  |  |  |  |  | 12-036F |  |  |  |  |  |  |  |  |  |  | 0 | 558000 | 55800000 | 100 | 4315 |  |  |  |  |  |  |  |  |  |  |  |  | 12-023 |  |  |
| 14315045D |  | Vend Fab Yoke Steel SHMS Q3 Cast/Annel Comp. Cast Deliv.Accept |  | 154d | 2012-01-12 A | 2012-08-20 A | 14315045C FS-163d | 100% |  |  | PROCUREMENT>$50K 69 NO ESCALATION | 190,000 |  | 0 | 190000 | FENKER H | 1 | 1 |  | P | HOWARD F |  |  |  |  |  |  |  |  |  |  | 12-036F |  |  |  |  |  |  |  |  |  |  | 0 | 190000 | 19000000 | 100 | 4315 |  |  |  |  |  |  |  |  |  |  |  |  | 12-023 |  |  |
| 14315045F |  | Vend Fab Yoke Steel SHMS Q2 Cast/Annel Comp. Cast Deliv/Accept |  | 193d | 2012-01-12 A | 2012-10-15 A | 14315045D FS-205d, 14315044LOEa FS-281d, 14315044LOE FS-281d | 100% |  |  | PROCUREMENT>$50K 69 NO ESCALATION | 128,000 |  | 0 | 128000 | FENKER H | 1 | 1 |  | P | HOWARD F |  |  |  |  |  |  |  |  |  |  | 12-036F |  |  |  |  |  |  |  |  |  |  | 0 | 128000 | 12800000 | 100 | 4315 |  |  |  |  |  |  |  |  |  |  |  |  | 12-023 |  |  |
| 14315020 |  | Ship Superconductor for Q2/3 and Dipole to Magnet Vendor |  | 340d | 2012-01-16 A | 2013-07-15 A | 14315018, 14315019B FS-473d, 14315015A5a FS-85d, 14315015A5 FS-85d, 14315019 FS-240d | 100% | 2012-01-17 | 2013-05-24 | SUPPLIES & MATERIALS | 12,500 |  | 0 | 12500 | FENKER H | 1 | 1 | 07-034 | H | HOWARD F | 08-048 |  | 10-069 | 11-026 |  | 10-008 | 11-017 | 11-025 | 11-046 | 12-012 | 12-036F |  |  |  |  |  |  |  |  |  |  |  |  |  |  |  |  |  |  |  |  |  |  |  | 14315020 |  |  |  |  |  |  |
| 14315036 |  | Proc Instruments & Controls for Q2/3 and Dipole magnets Part A |  | 180d | 2012-02-01 A | 2012-10-15 A | 9-120M FS+100d, 14315032 | 100% |  |  | PROCUREMENT>$50K 69; PROCUREMENT<$50K 60 | 133,000 |  | 0 | 133000 | FENKER H | 1 | 1 | 07-034 | S | HOWARD F | 08-048 |  | 10-069 | 11-026 |  |  |  |  |  | 12-012 | 12-036F |  |  | 09-022 | ST |  |  |  |  |  |  | 0 | 133000 | 13300000 | 100 | 4315 |  | 08-052 |  |  |  |  |  |  |  |  |  |  |  | 12-022 |  |
| 14315044LOE |  | Travel Expenses to Yoke Steel Casting Vendor FY12 |  | 169d | 2012-02-01 A | 2012-09-28 A | 14315045 FS-42d | 100% |  |  | TRAVEL | 31,529.85 |  | 0 | 31529.85 | FENKER H | 1 | 1 |  | E | HOWARD F |  |  |  |  |  |  |  |  |  |  | 12-036F | 100 | 100 |  |  |  |  |  |  |  |  |  |  |  |  |  |  |  |  |  |  |  | 44.02985074 | 55.97014925 |  |  |  |  | 12-023 |  | 12-053 |
| 14315046b |  | Procure Yoke Hardware |  | 41d | 2012-02-09 A | 2012-04-06 A | 14315046a FS-110d | 100% |  |  | PROCUREMENT<$50K 60 NO ESCALATION FY13 | 15,000 |  | 0 | 15000 | FENKER H | 1 | 1 | 07-034 | P | HOWARD F | 08-048 |  | 10-069 | 11-026 | 13-006F |  |  | 11-025 | 11-046 | 12-012 | 12-036F |  |  |  |  |  |  |  |  |  |  | 0 | 15000 | 1500000 | 100 | 4315 |  | 08-052 |  |  |  |  |  |  |  |  |  |  |  |  |  |
| 14315046 |  | Large Magnet Yoke Machining |  | 345d | 2012-02-13 A | 2013-06-24 A | 14315042, 9-120M FS+45d, 14315045B FS-150d | 100% | 2012-02-13 | 2013-06-28 | PROCUREMENT<$50K 60 NO ESCALATION FY13; PROCUREMENT>$50K 69 NO ESCALATION FY13 | 480,000 |  | 124800 | 480000 | FENKER H | 1 | 1 | 07-034 | D | HOWARD F | 08-048 |  | 10-069 | 11-026 | 13-006F |  |  |  | 11-046 | 12-012 | 12-036 |  |  |  |  |  |  |  |  |  |  | 0 | 480000 | 48000000 | 100 | 4315 |  | 08-052 |  |  | MP |  |  |  |  |  |  |  |  |  |  |
| 14315015B |  | Obtain RRR Measurement of Copper Part A |  | 158d | 2012-02-15 A | 2012-09-28 A | 14315015 FS+5d, 14315015A FS-50d | 100% | 2012-02-15 | 2012-09-27 | PROCUREMENT<$50K 60 NO ESCALATION FY11 | 12,500 |  | 0 | 12500 | FENKER H | 1 | 1 |  | H | HOWARD F |  |  | 10-069 | 11-026 |  |  | 11-017 | 11-025 | 11-046 | 12-012 | 12-036F |  |  |  |  |  |  |  |  |  |  | 0 | 12500 | 1250000 | 100 | 4315 |  |  | 10-057 |  |  |  |  |  |  | 12-055 |  |  |  |  |  |
| 14315029 |  | Inspect & Ship Cryo Reservoirs for Q2/3 & Dipole magnets |  | 52d | 2012-03-02 A | 2012-05-14 A | 14315027, 14315027H FS-21d, 14315026, 14315027J FS-21d, 14315027G | 100% |  |  | SUPPLIES & MATERIALS; MECH ENG [480 h]; MECH DES [640 h] | 82,036.49 | 64,486.4 | 0 | 82036.49 | FENKER H | 1 | 1 | 07-034 | D | HOWARD F | 08-048 |  | 10-069 | 11-026 |  |  | 11-017 |  |  | 12-012 | 12-036F |  |  | 09-022 |  |  |  |  |  |  |  |  |  |  |  |  | 10-022 |  |  |  |  |  |  |  |  |  |  |  |  |  |  |
| 14315043 |  | Dipole Top and Bottom Plates |  | 70d | 2012-03-02 A | 2012-06-11 A | 9-120M FS+95d | 100% |  |  | PROCUREMENT<$50K 60; PROCUREMENT>$50K 69 | 190,000 |  | 0 | 190000 | FENKER H | 1 | 1 | 07-034 | D | HOWARD F | 08-048 |  | 10-069 | 11-026 |  |  |  |  |  | 12-012 | 12-036F |  |  | 09-022 |  |  |  |  |  |  |  | 0 | 190000 | 19000000 | 100 | 4315 |  | 08-052 |  |  |  |  |  |  |  |  |  |  |  |  |  |
| 14315046a |  | Vend Fab Yoke supports and cylinders |  | 143d | 2012-04-02 A | 2012-10-22 A | 9-120M FS+5d, 14315042 | 100% |  |  | PROCUREMENT<$50K 60; PROCUREMENT>$50K 69 | 108,349.5 |  | 0 | 108349.5 | FENKER H | 1 | 1 | 07-034 | D | HOWARD F | 08-048 |  | 10-069 | 11-026 | 13-006F |  |  | 11-025 | 11-046 | 12-012 | 12-036F |  |  |  |  |  |  |  |  |  |  | 0 | 108349.5 | 10834950 | 100 | 4315 |  | 08-052 |  |  | MP |  |  |  |  |  |  |  |  |  |  |
| 14315037 |  | Assemble & Test Instruments & Controls Phase 3 FY12 |  | 269d | 2012-07-02 A | 2013-08-30 A | 14315036 FS-100d, 14315037a FS-130d | 100% | 2012-07-02 | 2013-07-30 | ELEC TECH [735.97 h]; MECH ENG [754.84 h]; ELEC ENG [75.48 h]; MECH DES [301.94 h]; MECH TECH [226.45 h] | 118,149.71 | 118,218.53 | 68051.481165 | 115341.4935 | FENKER H | 1 | 1 | 07-034 | S | HOWARD F | 08-048 |  | 10-069 | 11-026 |  |  |  |  |  | 12-012 | 12-036F |  |  | 09-022 | ST |  |  |  |  |  |  |  |  |  |  |  |  |  |  |  |  |  |  |  | 14315037 |  |  |  |  |  | 12-053 |
| 14315037b |  | Assemble & Test Instruments & Controls Phase 3 FY13 |  | 269d | 2012-07-02 A | 2013-08-30 A | 14315037 FS-230d | 100% | 2012-07-02 | 2013-07-30 | MECH ENG [845.16 h]; ELEC TECH [824.03 h]; ELEC ENG [84.52 h]; MECH DES [338.06 h]; MECH TECH [253.55 h] | 132,287.15 | 132,364.48 | 78628.574654 | 133268.7706 | FENKER H | 1 | 1 | 07-034 | S | HOWARD F | 08-048 |  | 10-069 | 11-026 |  |  |  |  |  | 12-012 | 12-036F |  |  | 09-022 | ST |  |  |  |  |  |  |  |  |  |  |  |  |  |  |  |  |  |  |  | 14315037b |  |  | 10-076 |  |  | 12-053 |
| 14315044LOEa |  | Travel Expenses to Yoke Steel Casting Vendor FY13 |  | 6d | 2012-09-10 A | 2012-09-17 A | 14315044LOE | 100% |  |  | TRAVEL | 19,059.35 |  | 0 | 19059.35 | FENKER H | 1 | 1 |  | E | HOWARD F |  |  |  |  |  |  |  |  |  |  | 12-036F |  |  |  |  |  |  |  |  |  |  |  |  |  |  |  |  |  |  |  |  |  | 0 |  |  |  |  |  | 12-023 |  | 12-053 |
| 14315015A5a |  | Completion of Solder SC Cable to Extrusion Part B |  | 11d | 2012-10-01 A | 2012-10-15 A | 14315015A FS-88d | 100% |  |  | PROCUREMENT>$50K 69 | 15,000 |  | 0 | 15000 | FENKER H | 1 | 1 |  | D | HOWARD F |  |  | 10-069 | 11-026 |  |  | 11-017 | 11-025 | 11-046 | 12-012 | 12-036F |  |  |  |  |  |  |  |  |  |  | 0 | 15000 | 1500000 | 100 | 4315 |  |  | 10-057 |  |  |  |  |  |  | 12-055 |  |  |  |  |  |
| 14315019A |  | Dimensional Inspection of Soldered Conductor at Vendor |  | 80d | 2013-01-01 A | 2013-01-31 A | 9-130M FS+59d | 100% | 2013-02-01 | 2013-05-24 | MECH ENG [240 h]; MECH DES [480 h] | 41,227.2 | 41,227.2 | 0 | 41227.2 | FENKER H | 1 | 1 |  | D | HOWARD F |  |  |  |  | 13-006 |  |  |  |  |  |  |  |  |  |  |  |  |  |  |  |  |  |  |  |  |  |  |  |  |  |  |  |  |  |  |  |  |  |  |  |  |
| 14315019B |  | Materials to support Conductor Inspection at Vendor |  | 80d | 2013-01-01 A | 2013-01-28 A | 14315019A FS-80d | 100% | 2013-02-01 | 2013-05-24 | PROCUREMENT<$50K 60 | 25,000 |  | 0 | 25000 | FENKER H | 1 | 1 |  | D | HOWARD F |  |  |  |  | 13-006 |  |  |  |  |  |  |  |  |  |  |  |  |  |  |  |  | 0 | 25000 | 2500000 | 100 |  |  |  |  |  |  |  |  |  |  |  |  |  |  |  |  |
| 14315050LOEg |  | Procurement Oversight FY13 |  | 189d | 2013-01-02 A | 2013-08-30 A | 14315050LOEf FS+60d | 100% | 2013-02-01 | 2013-10-29 | MECH ENG [214.6 h]; MECH DES [71.53 h] | 19,152.54 | 19,084.82 | 4742.45904 | 19084.82265 | FENKER H | 1 | 1 |  | E | HOWARD F |  |  |  |  | 13-006 |  |  |  |  |  |  | 100 | 100 |  |  |  |  |  |  |  |  |  |  |  |  |  |  |  |  |  |  |  | 10.58201058 | 89.41798941 |  |  |  |  |  |  |  |
| 14315015Ba |  | Obtain RRR Measurement of Copper Part B |  | 55d | 2013-07-01 A | 2013-08-30 A | 14315015 FS+5d, 14315015A FS-50d, 9-130M FS+200d | 100% | 2013-08-01 | 2013-10-17 | PROCUREMENT<$50K 60 NO ESCALATION FY11 | 12,500 |  | 6250 | 12500 | FENKER H | 1 | 1 |  | H | HOWARD F |  |  | 10-069 | 11-026 |  |  | 11-017 | 11-025 | 11-046 | 12-012 | 12-036F |  |  |  |  |  |  |  |  |  |  | 0 | 12500 | 1250000 | 100 | 4315 |  |  | 10-057 |  |  |  |  |  |  | 12-055 |  |  |  |  |  |
| 14315031M |  | Q1 Magnet Vendor Receipt of Cryoresevoir | milestone | 0d | 2013-07-15 A | 2013-07-15 A | 14315028 | 100% | 2013-10-02 | 2013-10-02 |  |  |  |  | 0 | FENKER H | 1 | 1 | 07-034 | M | HOWARD F | 08-048 |  | 10-069 | 11-026 |  |  |  |  | 11-046 | 12-012 | 12-036F |  |  | 09-022 |  |  | 10-063 |  |  | 12-003 |  |  |  |  |  |  | 10-022 |  |  |  |  |  |  |  | 14315031M |  |  |  |  |  |  |

Notes:
- 14315030: Steps: Hi-level Specs (done); 40 Wiring Schedules Done (done); 80 Wiring Schedules Done (done); All (approx. 100) Wiring Schedules Complete (done); Schedules Checked (done); Select Components to Purchase (done)
- 14315030b: Steps: Hi-level Specs (done); 40 Wiring Schedules Done (done); 80 Wiring Schedules Done (done); All (approx. 100) Wiring Schedules Complete (done); Schedules Checked (done); Select Components to Purchase (done)
- 14315002: Explanation: This activity was given an actual start of 23Nov2009, no physical progress. / The actual start was removed to faciliate in the development of Change Request / 10-008. / Activity is to be restarted in December 2009. / PMC 03Dec2009.
- 14315003: Explanation: This activity was given an actual start of 23Nov2009, no physical progress. / The actual start was removed to faciliate in the development of Change Request / 10-008. / Activity is to be restarted in December 2009. / PMC 03Dec2009.
- 14315037a: Steps: Adjust Controls per DCPS final design (done); Assemble Rack #1 (done); Assemble Rack #2 (done); Assemble Rack #3 (done); Assemble Rack #4 (done); Install Modules in Rack #1 (done); Install Modules in Rack #2 (done); Install Modules in Rack #3 (done); Install Modules in Rack #4 (done); Perform Internal wiring of Rack #1 (done); Perform Internal wiring of Rack #2 (done); Perform Internal wiring of Rack #3 (done); Perform Internal wiring of Rack #4 (done); Module/Electrical tests of Rack #1 (done); Module/Electrical tests of Rack #2 (done); Module/Electrical tests of Rack #3 (done); Module/Electrical tests of Rack #4 (done); Calibrate Analog Front-Ends -Rack #1 (done); Calibrate Analog Front-Ends -Rack #2 (done); Calibrate Analog Front-Ends -Rack #3 (done); Calibrate Analog Front-Ends -Rack #4 (done); Customize Software for Rack #1 (done); Customize Software for Rack #2 (done); Customize Software for Rack #3 (done); Customize Software for Rack #4 (done); Integrate Racks into Syatem (done)
- 14315036: Steps: Procure heat exchanger rack (done); Procure heat exchanger I/O modules (done); Procure heat exchanger signal conditioner (done); Procure PSU communication equipment (done); Proc magnet-to-controls cables & conn (done)
- 14315037: Steps: Reconfigure & rack layout - five racks (done); Detail final controls layout in hut (done); Prep Procurement of Heat Exchanger Rack (done); Prep Procurement of PSU Communication Eqpt (done); Install PSU Communication Equipment (done); Re-check Internal Wiring: HB,Q1,Q2,Q3,D racks (done); Populate Heat Exchanger Rack (done); Connect Q1,Q2,Q3,D rack internal wiring to I/O modules (done); Program magnet controls routines (done); Prep Procurement of Cables: Controls, HX, XFER line (done); Terminate magnet-to-controls cables, heat-exchanger controls cables, and transfer line sensor cables (done); Install magnet-to-controls cables, heat-exchanger controls cables, and transfer line sensor cables (done); Make HB Controls Operational (done); Calibrate Quench Det. Sys. for HB (done); Calibrate Remaining Quench Det. Sys. (done); Prep, Procure, & Assemble of Field-measurement Eqpt (done); Program rotation system (done); Develop Rotation GUI (done); Rotation Controls Checkout: software & GUI (done); Prep Procurement: rotation control cables (done); Prep Procurement of New/Replacement Rotation System Hardware (done); Install Rotation System Hardware (done); Assemble & Connect Rotation Control Cables (done); Test & Commission Rotation System (done); Prep Procurement of Licenses for Interface Hardware & Software (done)
- 14315037b: Steps: Reconfigure & rack layout - five racks (done); Detail final controls layout in hut (done); Prep Procurement of Heat Exchanger Rack (done); Prep Procurement of PSU Communication Eqpt (done); Install PSU Communication Equipment (done); Re-check Internal Wiring: HB,Q1,Q2,Q3,D racks (done); Populate Heat Exchanger Rack (done); Connect Q1,Q2,Q3,D rack internal wiring to I/O modules (done); Program magnet controls routines (done); Prep Procurement of Cables: Controls, HX, XFER line (done); Terminate magnet-to-controls cables, heat-exchanger controls cables, and transfer line sensor cables (done); Install magnet-to-controls cables, heat-exchanger controls cables, and transfer line sensor cables (done); Make HB Controls Operational (done); Calibrate Quench Det. Sys. for HB (done); Calibrate Remaining Quench Det. Sys. (done); Prep, Procure, & Assemble of Field-measurement Eqpt (done); Program rotation system (done); Develop Rotation GUI (done); Rotation Controls Checkout: software & GUI (done); Prep Procurement: rotation control cables (done); Prep Procurement of New/Replacement Rotation System Hardware (done); Install Rotation System Hardware (done); Assemble & Connect Rotation Control Cables (done); Test & Commission Rotation System (done); Prep Procurement of Licenses for Interface Hardware & Software (done)

| ID | WBS | Activity | Type | Duration | Start | Finish | Predecessors | Complete | Remaining | Planned start | Planned finish | Total float | Free float | Calendar | Resources | Cost | Actual cost | MONTHLY EV COST | RESP - Responsibility | STRT%COMP for CM EVM | FNSH%COMP for CM EVM | EVMS Reporting Codes | CAM RESPONSIBLE | CR 13-006 | Claimed Material Divider | ReBaseline Actuals Adjustment | Original Activity ID Rebaseline | Remaining Material Cost Based on % Compl | Claimed Material Cost Based on % Complet | Initial Claimed Material Calc | PRIOR MONTH EV COST | 12 GEV MAJOR PROCUREMENT CATAGORY | CR 10-057 | CR 10-069 | CR 10-076 | CR 11-017 | CR 11-025 | CR 11-026 | CR 11-046 | CR 12-012 | CR 12-036 | CR 12-055 | BOE Procurement | CR 13-015 | Post Rebaseline | Obligated Prior to Rebaseline | CR 14-001 | CR 07-034 | CR 08-048 | CR 08-052 | Activities with Steps | CR 09-022 | CR 12-022 | BOE NOTES | Pre Rebaseline Remaining Budget | CR 12-053 | BOE Labor | Previously In Progress | CR 10-075 | CR 12-003 | CR 12-054 | Inter Project Link (IPL) | BOE Adder | LOE Divider | LOE Multiplier | Milestone Level | Specification | CR 07-024 | CR 08-016 | CR 09-012 | MARCH!!! | LOE % Pre Calc | LOE % | Calculated Remaining Total Cost |
| --- | --- | --- | --- | --- | --- | --- | --- | --- | --- | --- | --- | --- | --- | --- | --- | --- | --- | --- | --- | --- | --- | --- | --- | --- | --- | --- | --- | --- | --- | --- | --- | --- | --- | --- | --- | --- | --- | --- | --- | --- | --- | --- | --- | --- | --- | --- | --- | --- | --- | --- | --- | --- | --- | --- | --- | --- | --- | --- | --- | --- | --- | --- | --- | --- | --- | --- | --- | --- | --- | --- | --- | --- | --- | --- |
| 14315100 |  | Install Moeller Quad #2 (6GEV) |  | 1d | 2013-08-01 A | 2013-08-01 A | 14351010, 14315020 | 100% |  |  |  |  |  |  |  |  |  | 0 | FENKER H | 1 | 1 | Z | HOWARD F | 13-006 |  |  |  |  |  |  |  |  |  |  |  |  |  |  |  |  |  |  |  |  |  |  |  |  |  |  |  |  |  |  |  |  |  |  |  |  |  |  |  |  |  |  |  |  |  |  |  |  |  |  |
| 14315105 |  | Re-Baseline Actuals Adjustment |  | 1d | 2013-08-30 A | 2013-08-30 A |  | 100% |  | 2013-09-03 | 2013-09-03 |  |  |  | PROCUREMENT>$50K 69 NO ESCALATION | -10,617.18 |  |  |  |  |  |  |  |  | 100 | ADJ |  |  |  |  |  |  |  |  |  |  |  |  |  |  |  |  |  |  |  |  |  |  |  |  |  |  |  |  |  |  |  |  |  |  |  |  |  |  |  |  |  |  |  |  |  |  |  |  |
| 24315015Ba |  | Obtain Short-Sample SC Measurements |  | 98d | 2013-09-03 A | 2013-09-23 A | 9-130M FS+228d | 100% |  | 2013-09-03 | 2014-01-31 |  |  | 8/5 M-F w/JLAB Holidays ReBaseline | PROCUREMENT<$50K 60 | 15,278.28 |  | 0 | FENKER H | 1 | 1 | D | HOWARD F | 13-006F | 100 |  | 24315015Ba | 0 | 15278.28 | 1527828 | 15278.28 | 4315 | 10-057 | 10-069 | 10-076 | 11-017 | 11-025 | 11-026 | 11-046 | 12-012 | 12-036F | 12-055 | PE | 13-015 | PR | OB |  |  |  |  |  |  |  |  |  |  |  |  |  |  |  |  |  |  |  |  |  |  |  |  |  |  |  |  |
| 24315015Bb |  | Obtain RRR Measurement of Copper Part B FY13 |  | 44d | 2013-09-03 A | 2013-11-15 | 9-130M FS+228d | 50% | 11d | 2013-09-03 | 2013-11-01 | 517d | 49d | 8/5 M-F w/JLAB Holidays ReBaseline | ELEC TECH [36.36 h] | 1,684.59 | 1,340.99 | 0 | FENKER H | 1 | 1 | D | HOWARD F | 13-006F |  |  | 24315015Ba |  |  |  | 827.9172 | 4315 | 10-057 | 10-069 | 10-076 | 11-017 | 11-025 | 11-026 | 11-046 | 12-012 | 12-036F | 12-055 | PE | 13-015 | PR |  |  |  |  |  |  |  |  |  |  |  |  |  |  |  |  |  |  |  |  |  |  |  |  |  |  |  |  |  |
| 24315015Bba |  | Obtain RRR Measurement of Copper Part B FY14 |  | 24d | 2013-09-03 A | 2013-11-15 | 24315015Bb FS-60d | 50% | 11d | 2013-10-01 | 2013-11-01 | 955d | 1010d | 8/5 M-F w/JLAB Holidays ReBaseline | ELEC TECH [43.64 h] | 2,050.64 | 1,609.48 | 0 | FENKER H | 1 | 1 | D | HOWARD F | 13-006F |  |  | 24315015Ba |  |  |  | 1025.3218 | 4315 | 10-057 | 10-069 | 10-076 | 11-017 | 11-025 | 11-026 | 11-046 | 12-012 | 12-036F | 12-055 | PE | 13-015 | PR |  | 14-001 |  |  |  |  |  |  |  |  |  |  |  |  |  |  |  |  |  |  |  |  |  |  |  |  |  |  |  |
| 24315036a5 |  | Proc Instruments & Controls for Q2/3 and Dipole magnets Part B |  | 98d | 2013-09-03 A | 2013-09-23 A | 9-130M FS+228d | 100% |  | 2013-09-03 | 2014-01-31 |  |  | 8/5 M-F w/JLAB Holidays ReBaseline | PROCUREMENT<$50K 60 NO ESCALATION FY14 | 15,000 |  | 0 | FENKER H | 1 | 1 | S | HOWARD F | 13-006 | 100 |  | 24315036a5 | 0 | 15000 | 1500000 | 15000 | 4315 |  | 10-069 | 10-076 |  |  | 11-026 |  | 12-012 | 12-036F |  | PE | 13-015 | PR | OB |  | 07-034 | 08-048 | 08-052 | ST | 09-022 | 12-022 |  |  |  |  |  |  |  |  |  |  |  |  |  |  |  |  |  |  |  |  |  |
| 24315037b |  | Assemble & Test Instruments & Controls Phase 3 FY13 |  | 127d | 2013-09-03 A | 2014-03-13 | 9-130M FS+228d |  | 84d | 2013-10-01 | 2014-04-10 | 245d | 2d | 8/5 M-F w/JLAB Holidays ReBaseline | MECH ENG [173.04 h]; MECH DES [33.76 h]; MECH TECH [25.32 h] | 15,850.93 | 5,289.62 | 0 | FENKER H | 1 | 1 | S | HOWARD F | 13-006F |  |  | 24315037b |  |  |  |  |  |  | 10-069 | 10-076 |  |  | 11-026 |  | 12-012 | 12-036F |  |  | 13-015 | PR |  |  | 07-034 | 08-048 |  | ST | 09-022 |  | OPEN OBLIGATION | 215897.7 | 12-053 | PE | Review |  |  |  |  |  |  |  |  |  |  |  |  |  |  |  |  |
| 24315037ba |  | Assemble & Test Instruments & Controls Phase 3 FY14 |  | 107d | 2013-09-03 A | 2014-03-13 | 24315037b FS-110d |  | 84d | 2013-10-01 | 2014-03-13 | 882d | 937d | 8/5 M-F w/JLAB Holidays ReBaseline | MECH ENG [925.76 h]; MECH DES [180.64 h]; MECH TECH [135.48 h] | 84,803.69 | 28,299.9 | 0 | FENKER H | 1 | 1 | S | HOWARD F | 13-006F |  |  | 24315037b |  |  |  |  |  |  | 10-069 | 10-076 |  |  | 11-026 |  | 12-012 | 12-036F |  |  | 13-015 | PR |  | 14-001 | 07-034 | 08-048 |  | ST | 09-022 |  | OPEN OBLIGATION | 215897.7 | 12-053 | PE | Review |  |  |  |  |  |  |  |  |  |  |  |  |  |  |  |  |
| 24315050LOEg |  | Procurement Oversight FY13 |  | 20d | 2013-09-03 A | 2013-09-30 A | 9-130M FS+228d | 100% |  | 2013-10-01 | 2013-10-28 |  |  | 8/5 M-F w/JLAB Holidays ReBaseline | MECH ENG [25.39 h]; MECH DES [8.46 h] | 2,330.49 | 2,258.38 | 0 | FENKER H | 1 | 1 | E | HOWARD F | 13-006 |  |  | 24315050LOEg |  |  |  | 2258.37735 |  |  |  |  |  |  |  |  |  |  |  |  |  | PR |  |  |  |  |  |  |  |  |  |  |  | PE |  |  |  |  |  |  |  |  |  |  |  |  |  |  |  |  |  |
| 24315080 |  | Vend Fab DCPS - Arrival Test of Items 1&2 |  | 62d | 2013-09-03 A | 2014-03-03 | 9-130M FS+228d |  | 76d | 2013-09-03 | 2013-11-27 | 456d | 4d | 8/5 M-F w/JLAB Holidays ReBaseline | PROCUREMENT>$50K 69 NO ESCALATION | 14,000 |  | 0 | FENKER H | 1 | 1 | D | HOWARD F | 13-006F | 100 |  | 24315080 | 14000 | 0 | 0 |  |  |  |  | 10-076 |  |  | 11-026 | 11-046 | 12-012 | 12-036F |  | OB | 13-015 | PR | OB |  |  |  |  |  |  |  | OPEN OBLIGATION |  |  |  |  | 10-075 | 12-003 | 12-054F |  |  |  |  |  |  |  |  |  |  |  |  |  |
| 24315090 |  | Vend Fab DCPS - Arrival Test of Items 3,4,&5 |  | 62d | 2013-09-03 A | 2014-03-03 | 24315080 FS-80d |  | 76d | 2013-09-03 | 2013-11-27 | 452d |  | 8/5 M-F w/JLAB Holidays ReBaseline | PROCUREMENT>$50K 69 NO ESCALATION | 26,660 |  | 0 | FENKER H | 1 | 1 | D | HOWARD F |  | 100 |  | 24315090 | 26660 | 0 | 0 |  |  |  |  | 10-076 |  |  | 11-026 |  |  |  |  | OB | 13-015 | PR | OB |  |  |  |  |  |  |  | OPEN OBLIGATION |  |  |  |  | 10-075 |  |  |  |  |  |  |  |  |  |  |  |  |  |  |  |
| 24315007 |  | Test & Integrate DC Pwr Sys for all magnets |  | 60d | 2014-06-04 | 2014-08-27 | 24368265, 9-140M, 24368135 |  |  |  |  | 329d |  | 8/5 M-F w/JLAB Holidays ReBaseline | ELEC TECH [340 h]; ELEC ENG [340 h] | 41,520.8 |  | 0 | FENKER H | 1 | 1 | S | HOWARD F | 13-006F |  |  | 24315007 |  |  |  |  |  |  | 10-069 | 10-076 |  |  | 11-026 |  | 12-012 | 12-036F |  |  | 13-015 | PR |  | 14-001 | 07-034 | 08-048 | 08-052 | ST | 09-022 |  |  |  |  | PE |  |  |  | 12-054 | IPL |  |  |  |  |  |  |  |  |  |  |  |  |
|  | 6 | **1.4.3.1.6 HALL C SPARE COILS** |  |  | 2014-10-01 | 2015-12-01 |  |  |  |  |  |  |  |  |  |  |  |  |  |  |  |  |  |  |  |  |  |  |  |  |  |  |  |  |  |  |  |  |  |  |  |  |  |  |  |  |  |  |  |  |  |  |  |  |  |  |  |  |  |  |  |  |  |  |  |  |  |  |  |  |  |  |  |  |
|  | 1 | **1.4.3.1.6.1 CONSTRUCTION HALL C SPARE COILS** |  |  | 2014-10-01 | 2015-12-01 |  |  |  |  |  |  |  |  |  |  |  |  |  |  |  |  |  |  |  |  |  |  |  |  |  |  |  |  |  |  |  |  |  |  |  |  |  |  |  |  |  |  |  |  |  |  |  |  |  |  |  |  |  |  |  |  |  |  |  |  |  |  |  |  |  |  |  |  |
| 243161000 |  | Vendor wind Spare Q2/Q3 Coil |  | 97d | 2014-10-01 | 2015-02-27 | 24313017 FS-141d, 9-155M |  |  |  |  | 23d | 22d | 8/5 M-F w/JLAB Holidays ReBaseline | PROCUREMENT>$50K 69; PROCUREMENT<$50K 60 | 206,380 |  | 0 | FENKER H | 1 | 1 | P | HOWARD F | 13-006 | 100 |  | 24313019b | 206380 | 0 | 0 |  | 4313 |  |  |  | 11-017 |  | 11-026 |  |  | 12-036F |  | OB | 13-015 | PR |  | 14-001 |  |  |  |  |  |  | OPEN OBLIGATION |  |  |  |  |  |  |  |  | YES |  |  |  |  |  |  |  |  |  |  |  |
| 243161005 |  | Vendor Prepare Tooling to wind Spare Dipole Coil |  | 15d | 2014-10-01 | 2014-10-21 | 9-155M, 24313017 FS-141d |  |  |  |  | 1d | 0d | 8/5 M-F w/JLAB Holidays ReBaseline | PROCUREMENT>$50K 69 | 25,797.5 |  | 0 | FENKER H | 1 | 1 | P | HOWARD F | 13-006 | 100 |  | 24313019b | 25797.5 | 0 | 0 |  | 4313 |  |  |  | 11-017 |  | 11-026 |  |  | 12-036F |  | OB | 13-015 | PR |  | 14-001 |  |  |  |  |  |  | OPEN OBLIGATION |  |  |  |  |  |  |  |  | YES |  |  |  |  |  |  |  |  |  |  |  |
| 243161030LOE |  | Oversight of Spare Coil Winding |  | 119d | 2014-10-01 | 2015-03-31 | 9-155M |  |  |  |  | 233d | 149d | 8/5 M-F w/JLAB Holidays ReBaseline | MECH ENG [952 h]; TRAVEL | 94,684.22 |  | 0 | FENKER H | 1 | 1 | P | HOWARD F | 13-006 |  |  | 24313019b |  |  |  |  | 4313 |  |  |  | 11-017 |  | 11-026 |  |  | 12-036F |  | OB | 13-015 | PR |  | 14-001 |  |  |  |  |  |  | OPEN OBLIGATION |  |  |  |  |  |  |  |  | YES | 100 | 100 |  |  |  |  |  |  |  |  |  |
| 243161010 |  | Vendor wind Spare Dipole Coil |  | 104d | 2014-10-22 | 2015-03-31 | 243161005 |  |  |  |  | 1d | 0d | 8/5 M-F w/JLAB Holidays ReBaseline | PROCUREMENT>$50K 69 | 206,380 |  | 0 | FENKER H | 1 | 1 | P | HOWARD F | 13-006 | 100 |  | 24313019b | 206380 | 0 | 0 |  | 4313 |  |  |  | 11-017 |  | 11-026 |  |  | 12-036F |  | OB | 13-015 | PR |  | 14-001 |  |  |  |  |  |  | OPEN OBLIGATION |  |  |  |  |  |  |  |  | YES |  |  |  |  |  |  |  |  |  |  |  |
| 243161015 |  | Vendor storage of Spare Coils |  | 149d | 2015-04-01 | 2015-10-30 | 243161010, 243161000 |  |  |  |  | 1d | 0d | 8/5 M-F w/JLAB Holidays ReBaseline | PROCUREMENT>$50K 69 | 20,638 |  | 0 | FENKER H | 1 | 1 | P | HOWARD F | 13-006 | 100 |  | 24313019b | 20638 | 0 | 0 |  | 4313 |  |  |  | 11-017 |  | 11-026 |  |  | 12-036F |  | OB | 13-015 | PR |  | 14-001 |  |  |  |  |  |  | OPEN OBLIGATION |  |  |  |  |  |  |  |  | YES |  |  |  |  |  |  |  |  |  |  |  |
| 243161020 |  | Vendor ship spare coils to JLab |  | 20d | 2015-11-02 | 2015-12-01 | 243161015, 243161030LOE |  |  |  |  | 84d | 41d | 8/5 M-F w/JLAB Holidays ReBaseline | PROCUREMENT>$50K 69 | 25,797.5 |  | 0 | FENKER H | 1 | 1 | P | HOWARD F | 13-006 | 100 |  | 24313019b | 25797.5 | 0 | 0 |  | 4313 |  |  |  | 11-017 |  | 11-026 |  |  | 12-036F |  | OB | 13-015 | PR |  | 14-001 |  |  |  |  |  |  | OPEN OBLIGATION |  |  |  |  |  |  |  |  | YES |  |  |  |  |  |  |  |  |  |  |  |
|  | 2 | **1.4.3.2 DETECTOR** |  |  | 2009-08-05 | 2014-09-02 |  |  |  |  |  |  |  |  |  |  |  |  |  |  |  |  |  |  |  |  |  |  |  |  |  |  |  |  |  |  |  |  |  |  |  |  |  |  |  |  |  |  |  |  |  |  |  |  |  |  |  |  |  |  |  |  |  |  |  |  |  |  |  |  |  |  |  |  |
|  | 1 | **1.4.3.2.1 WIRE CHAMBERS** |  |  | 2009-09-14 | 2014-09-02 |  |  |  |  |  |  |  |  |  |  |  |  |  |  |  |  |  |  |  |  |  |  |  |  |  |  |  |  |  |  |  |  |  |  |  |  |  |  |  |  |  |  |  |  |  |  |  |  |  |  |  |  |  |  |  |  |  |  |  |  |  |  |  |  |  |  |  |  |
| 14321000M |  | Award Contract for Wire Chambs | milestone | 0d | 2009-09-14 A | 2009-09-14 A | 9-100M, 12232015 | 100% |  | 2009-10-01 | 2009-10-01 |  |  |  |  |  |  | 0 | FENKER H | 1 | 1 | M | HOWARD F |  |  |  |  |  |  |  |  |  |  | 10-069 |  |  |  | 11-026 | 11-046 | 12-012 |  |  |  |  |  |  |  |  |  |  |  | 09-022 |  |  |  |  |  |  |  |  |  |  |  |  |  | 6 |  |  |  |  |  |  |  |  |
| 14321005 |  | Fab Wire Chambers at University |  | 839d | 2009-09-14 A | 2013-08-26 A | 14321000M | 100% |  | 2009-09-14 | 2013-02-05 |  |  |  |  |  |  | 0 | FENKER H | 1 | 1 | Z | HOWARD F |  |  |  |  |  |  |  |  |  |  | 10-069 |  |  |  | 11-026 | 11-046 | 12-012 |  |  |  |  |  |  |  |  |  |  |  | 09-022 |  |  |  |  |  |  |  |  |  |  |  |  |  |  | 14321005 | 07-024 | 08-016 | 09-012 | XX |  |  |  |
| 143218P1LOE |  | P-1 Supervise Fab of Wire Chambs |  | 261d | 2009-09-14 A | 2010-09-30 A | 12232020, 14321000M | 100% |  |  |  |  |  |  |  |  |  | 0 | FENKER H | 1 | 1 | Z | HOWARD F |  |  |  |  |  |  |  |  |  |  | 10-069 |  |  |  | 11-026 | 11-046 |  |  |  |  |  |  |  |  |  |  |  |  | 09-022 |  |  |  |  |  |  |  |  |  |  |  | 100 | 100 |  |  | 07-024 |  | 09-012 |  |  |  |  |
| 143218P2LOE |  | P-2 Supervise Fab of Wire Chambs |  | 245d | 2010-10-01 A | 2011-09-27 A | 143218P1LOE | 100% |  |  |  |  |  |  | SCIENTIST [440 h] | 30,109.2 | 30,109.2 | 30109.2 | FENKER H | 1 | 1 | E | HOWARD F |  |  |  |  |  |  |  |  |  |  | 10-069 |  |  |  | 11-026 | 11-046 |  |  |  |  |  |  |  |  |  |  |  |  | 09-022 |  |  |  |  |  |  |  |  |  |  |  | 100 | 100 |  |  | 07-024 |  | 09-012 |  | 7.34693877 | 92.65306122 | 0 |
| 14321007 |  | Procure Connectors and Components |  | 563d | 2010-10-22 A | 2013-08-30 A | 9-100M FS+184d | 100% |  | 2010-10-22 | 2013-02-05 |  |  |  | PROCUREMENT<$50K 60 | 50,000 |  | 50000 | FENKER H | 1 | 1 | D | HOWARD F |  | 100 |  |  | 0 | 50000 | 5000000 |  | 4315 | 10-057 | 10-069 |  |  |  | 11-026 | 11-046 |  |  |  |  |  |  |  |  |  |  |  |  |  |  |  |  |  |  |  |  |  |  |  |  |  |  |  |  |  |  |  | XX |  |  | 5000 |
| 14321900 |  | Proc Prep and Fab of Drift Gas Manifold Parts Original |  | 4d | 2012-02-01 A | 2012-02-06 A | 14324001a | 100% |  |  |  |  |  |  | MECH DES [8 h] | 385.36 | 385.36 | 385.36 | FENKER H | 1 | 1 | H | HOWARD F |  |  |  |  |  |  |  |  |  |  | 10-069 |  |  | 11-025 |  | 11-046 |  |  |  |  |  |  |  |  |  |  |  |  |  | 12-022 |  |  |  |  |  |  |  |  |  |  |  |  |  |  |  |  |  |  |  |  | 0 |
| 14321900a |  | Reverse Entry per CR12-022 |  | 4d | 2012-02-01 A | 2012-02-06 A | 9-120M FS+80d | 100% |  |  |  |  |  |  | MECH DES [-8 h] | -385.36 | -385.36 |  | FENKER H | 1 | 1 | H | HOWARD F |  |  |  |  |  |  |  |  |  |  |  |  |  |  |  |  |  |  |  |  |  |  |  |  |  |  |  |  |  | 12-022 |  |  |  |  |  |  |  |  |  |  |  |  |  |  |  |  |  |  |  |  |  |
| 14321905 |  | Refurbish LVPS |  | 21d | 2012-03-02 A | 2012-03-30 A | 9-120M FS+80d | 100% |  |  |  |  |  |  | ELEC TECH [240 h] | 10,591.2 | 10,591.2 | 10591.2 | FENKER H | 1 | 1 | H | HOWARD F |  |  |  |  |  |  |  |  |  |  | 10-069 |  |  | 11-025 |  | 11-046 | 12-012 |  |  |  |  |  |  |  |  |  |  |  |  |  |  |  |  |  |  |  |  |  |  |  |  |  |  |  |  |  |  |  |  |  | 0 |
| 14321900b |  | Proc Prep and Fab of Drift Gas Manifold Parts Revised per CR12-022 |  | 134d | 2012-11-12 A | 2013-02-18 A | 14324001a, 9-130M | 100% |  | 2012-11-12 | 2013-05-31 |  |  |  | MECH DES [80 h]; PROCUREMENT<$50K 60 | 25,952.5 | 3,976.8 | 25952.5 | FENKER H | 1 | 1 | H | HOWARD F |  | 100 |  |  | 0 | 21975.7 | 2197570 |  |  |  |  |  |  |  |  |  |  |  |  |  |  |  |  |  |  |  |  |  |  | 12-022 |  |  |  |  |  |  |  | 12-054 |  |  |  |  |  | 14321900b |  |  |  |  |  |  | 0 |
| 14321910 |  | Re-Baseline Actuals Adjustment |  | 1d | 2013-08-30 A | 2013-08-30 A |  | 100% |  | 2013-09-03 | 2013-09-03 |  |  |  | PROCUREMENT>$50K 69 NO ESCALATION | -11,332.83 |  |  |  |  |  |  |  |  | 100 | ADJ |  |  |  |  |  |  |  |  |  |  |  |  |  |  |  |  |  |  |  |  |  |  |  |  |  |  |  |  |  |  |  |  |  |  |  |  |  |  |  |  |  |  |  |  |  |  |  |  |
| 14321015M |  | Test Wire Chambers at University | milestone | 0d | 2013-08-30 A | 2013-08-30 A | 14321005, 143218P2LOE, 14321007 | 100% |  | 2013-10-28 | 2013-10-28 |  |  |  |  |  |  | 0 | FENKER H | 1 | 1 | M | HOWARD F |  |  |  |  |  |  |  |  |  |  | 10-069 |  |  |  | 11-026 | 11-046 | 12-012 |  |  |  |  |  |  |  |  |  |  |  | 09-022 |  |  |  |  |  |  |  |  |  |  |  |  |  | 6 | 14321015M |  |  |  | XX |  |  |  |
| 24321007 |  | Procure Connectors and Components |  | 20d | 2013-09-03 A | 2013-09-30 A | 9-130M FS+228d | 100% |  | 2013-10-01 | 2013-10-28 |  |  | 8/5 M-F w/JLAB Holidays ReBaseline | PROCUREMENT<$50K 60 |  |  | 0 | FENKER H | 1 | 1 | D | HOWARD F | 13-006F |  |  | 24321007 |  |  |  |  | 4315 | 10-057 | 10-069 |  |  |  | 11-026 | 11-046 |  |  |  | PE | 13-015 | PR |  |  |  |  |  |  |  |  | OPEN OBLIGATION |  |  |  | Review |  |  |  |  |  |  |  |  |  |  |  |  |  |  |  |  |
| 24321015M |  | Test Wire Chambers at University | milestone | 0d | 2014-09-02 | 2014-09-02 | 9-140M FS+228d, 24321007 |  |  |  |  | 277d | 251d | 8/5 M-F w/JLAB Holidays ReBaseline |  |  |  | 0 | FENKER H | 1 | 1 | Z | HOWARD F | 13-006F |  |  | 24321015M |  |  |  |  |  |  | 10-069 |  |  |  | 11-026 | 11-046 | 12-012 |  |  |  | 13-015 | PR |  |  |  |  |  |  | 09-022 |  |  |  |  |  |  |  |  |  |  |  |  |  | 6 |  |  |  |  |  |  |  |  |

Notes:
- 24315036a5: Steps: Procure rotation system hardware (done); Proc licenses for intfc hdwr & sftwr (done)
- 24315037b: Steps: Software programming 25% done; Software programming 50% done; Software programming 75% done; Software programming Completed; Software Checkout; Software Documentation; HMI Development 50% done; HMI Development Completed; Program remote rotation system; Develop rotation HMI; Proc. Prep for Software Licences; Install procured software
- 24315037ba: Steps: Software programming 25% done; Software programming 50% done; Software programming 75% done; Software programming Completed; Software Checkout; Software Documentation; HMI Development 50% done; HMI Development Completed; Program remote rotation system; Develop rotation HMI; Proc. Prep for Software Licences; Install procured software
- 24315007: Explanation: IPL from 6 GeV 54342005 / Steps: Test Utililities Connected to DCPS (AC pwr, LCW, etc.); Test Controls Connected to DCPS; Test all possible interlocks connected - others bypassed & tagged.; Exercise first pair of DCPS simultaneously; Exercise second pair of DCPS simultaneously; Exercise third pair of DCPS simultaneously; Exercise all 5 DCPS w/o loads simultaneously using controls computer (not local DCPS controls)

| ID | WBS | Activity | Type | Duration | Start | Finish | Predecessors | Complete | Remaining | Planned start | Planned finish | Total float | Free float | Calendar | Resources | Cost | Actual cost | MONTHLY EV COST | RESP - Responsibility | STRT%COMP for CM EVM | FNSH%COMP for CM EVM | Milestone Level | EVMS Reporting Codes | CAM RESPONSIBLE | CR 09-022 | CR 10-069 | CR 11-026 | CR 11-046 | Specification | CR 07-024 | CR 08-016 | Activities with Steps | CR 09-012 | MARCH!!! | Calculated Remaining Total Cost | Remaining Material Cost Based on % Compl | Claimed Material Cost Based on % Complet | Initial Claimed Material Calc | Claimed Material Divider | ReBaseline Actuals Adjustment | LOE % Pre Calc | LOE % | LOE Divider | LOE Multiplier | CR 12-053 | CR 13-006 | BOE NOTES | Original Activity ID Rebaseline | PRIOR MONTH EV COST | BOE Procurement | CR 13-015 | Post Rebaseline | Obligated Prior to Rebaseline | BOE Labor | Previously In Progress | CR 14-001 | CR 12-001 | CR 12-022 |
| --- | --- | --- | --- | --- | --- | --- | --- | --- | --- | --- | --- | --- | --- | --- | --- | --- | --- | --- | --- | --- | --- | --- | --- | --- | --- | --- | --- | --- | --- | --- | --- | --- | --- | --- | --- | --- | --- | --- | --- | --- | --- | --- | --- | --- | --- | --- | --- | --- | --- | --- | --- | --- | --- | --- | --- | --- | --- | --- |
|  | 2 | **1.4.3.2.2 HODOSCOPE (Trigger Hodoscopes)** |  |  | 2009-08-05 | 2013-08-30 |  |  |  |  |  |  |  |  |  |  |  |  |  |  |  |  |  |  |  |  |  |  |  |  |  |  |  |  |  |  |  |  |  |  |  |  |  |  |  |  |  |  |  |  |  |  |  |  |  |  |  |  |
| 14322000M |  | Award Contract for Scintillator Hodoscope Planes | milestone | 0d | 2009-08-05 A | 2009-08-05 A | 9-100M | 100% |  | 2009-10-01 | 2009-10-01 |  |  |  |  |  |  | 0 | FENKER H | 1 | 1 | 6 | M | HOWARD F | 09-022 | 10-069 | 11-026 | 11-046 |  |  |  |  |  |  |  |  |  |  |  |  |  |  |  |  |  |  |  |  |  |  |  |  |  |  |  |  |  |  |
| 14322005M |  | Award Contract for Quartz Hodoscope Planes | milestone | 0d | 2009-08-27 A | 2009-08-27 A | 9-100M | 100% |  | 2009-10-01 | 2009-10-01 |  |  |  |  |  |  | 0 | FENKER H | 1 | 1 | 6 | M | HOWARD F | 09-022 | 10-069 | 11-026 | 11-046 |  |  |  |  |  |  |  |  |  |  |  |  |  |  |  |  |  |  |  |  |  |  |  |  |  |  |  |  |  |  |
| 14322010 |  | Fab 3 Scintillator Planes (incl Supprt) (HODOSCP) |  | 836d | 2009-09-08 A | 2013-01-28 A | 14322000M, 122322005 | 100% |  | 2009-09-08 | 2013-01-25 |  |  |  |  |  |  | 0 | FENKER H | 1 | 1 |  | Z | HOWARD F | 09-022 | 10-069 | 11-026 | 11-046 | 14322010 | 07-024 | 08-016 | NB | 09-012 | XX |  |  |  |  |  |  |  |  |  |  |  |  |  |  |  |  |  |  |  |  |  |  |  |  |
| 14322015 |  | Fab 1 Quartz Hodoscope Plane |  | 836d | 2009-09-08 A | 2013-01-28 A | 122322015b, 14322005M | 100% |  | 2009-09-08 | 2013-01-25 |  |  |  |  |  |  | 0 | FENKER H | 1 | 1 |  | Z | HOWARD F | 09-022 | 10-069 | 11-026 | 11-046 | 14322015 | 07-024 | 08-016 | NB | 09-012 | XX |  |  |  |  |  |  |  |  |  |  |  |  |  |  |  |  |  |  |  |  |  |  |  |  |
| 14322013 |  | Detail Quartz Hodoscope Mounts |  | 118d | 2011-08-18 A | 2012-02-13 A | 9-110M FS+170d, 14322005M | 100% |  |  |  |  |  |  | MECH DES [400 h]; MECH ENG [80 h] | 24,675.41 | 24,675.41 | 24108 | FENKER H | 1 | 1 |  | H | HOWARD F | 09-022 | 10-069 | 11-026 | 11-046 |  | 07-024 | 08-016 |  | 09-012 |  | 0 |  |  |  |  |  |  |  |  |  |  |  |  |  |  |  |  |  |  |  |  |  |  |  |
| 14322020 |  | Re-Baseline Actuals Adjustment |  | 1d | 2013-08-30 A | 2013-08-30 A |  | 100% |  | 2013-09-03 | 2013-09-03 |  |  |  | PROCUREMENT>$50K 69 NO ESCALATION | 2,135.01 |  | 2135.01 |  |  |  |  |  |  |  |  |  |  |  |  |  |  |  |  |  | 0 | 2135.01 | 213501 | 100 | ADJ |  |  |  |  |  |  |  |  |  |  |  |  |  |  |  |  |  |  |
|  | 3 | **1.4.3.2.3 NOBLE GAS CERENKOV** |  |  | 2012-01-05 | 2014-07-31 |  |  |  |  |  |  |  |  |  |  |  |  |  |  |  |  |  |  |  |  |  |  |  |  |  |  |  |  |  |  |  |  |  |  |  |  |  |  |  |  |  |  |  |  |  |  |  |  |  |  |  |  |
| 143238P1LOE |  | P-1 Supervise Constrctn of Noble Gas Cerenkov FY12 |  | 186.63d | 2012-01-05 A | 2012-09-28 A | 14323000M FS-40d, 122323015 | 100% |  |  |  |  |  |  | SCIENTIST [112.06 h] | 7,912.56 | 7,912.56 | 7912.5566 | FENKER H | 1 | 1 |  | E | HOWARD F | 09-022 | 10-069 | 11-026 | 11-046 |  |  |  |  |  |  | 0 |  |  |  |  |  | 37.07865168 | 62.92134831 | 100 | 100 | 12-053 | 13-006F |  |  |  |  |  |  |  |  |  |  |  |  |
| 14323010 |  | Design & Build Vacuum Box |  | 223d | 2012-04-02 A | 2013-08-30 A | 14323000M | 100% |  | 2012-04-02 | 2013-02-25 |  |  |  | MECH DES [200 h]; MECH ENG [80 h]; PROCUREMENT<$50K 60 | 42,073.77 | 15,556.5 | 41864.04 | FENKER H | 1 | 1 |  | S | HOWARD F | 09-022 | 10-069 | 11-026 | 11-046 | 14323010 |  | 08-016 | ST | 09-012 | XX | 14652.414 | 0 | 26620.44 | 2662044 | 100 |  |  |  |  |  |  | 13-006F |  |  |  |  |  |  |  |  |  |  |  |  |
| 14323000M |  | Award Contract for Noble Gas Cerenkov to University | milestone | 0d | 2012-04-27 A | 2012-04-27 A | 9-120M FS+120d | 100% |  | 2012-05-01 | 2012-05-01 |  |  |  |  |  |  | 0 | FENKER H | 1 | 1 | 6 | M | HOWARD F |  | 10-069 | 11-026 | 11-046 |  |  |  |  |  |  |  |  |  |  |  |  |  |  |  |  |  | 13-006F |  |  |  |  |  |  |  |  |  |  |  |  |
| 14323005 |  | Fab Noble Gas Cerenkov FY12 |  | 335d | 2012-04-27 A | 2013-08-30 A | 14323000M | 100% |  | 2012-04-27 | 2013-08-29 |  |  |  | MECH DES [280.15 h]; PLABOR; PD UNIV STAFF [672.36 h]; CONTRB UNIV LBR [364.19 h] | 61,855.35 | 52,383.68 | 60747.4839 | FENKER H | 1 | 1 |  | U | HOWARD F | 09-022 | 10-069 | 11-026 | 11-046 | 14323005 |  | 08-016 |  | 09-012 |  | 48597.98712 |  |  |  |  |  |  |  |  |  | 12-053 |  |  |  |  |  |  |  |  |  |  |  |  |  |
| 14323005a |  | Fab Noble Gas Cerenkov FY13 |  | 335d | 2012-04-27 A | 2013-08-30 A | 14323005 FS-185d | 100% |  | 2012-04-27 | 2013-08-29 |  |  |  | PLABOR; CONTRB UNIV LBR [155.81 h]; MECH DES [119.85 h]; PD UNIV STAFF [287.64 h] | 26,591.39 | 22,410.29 | 26816.8807 | FENKER H | 1 | 1 |  | U | HOWARD F | 09-022 | 10-069 | 11-026 | 11-046 | 14323005a |  | 08-016 |  | 09-012 |  | 21453.50456 |  |  |  |  |  |  |  |  |  | 12-053 |  |  |  |  |  |  |  |  |  |  |  |  |  |
| 14323005b |  | Fab Noble Gas Cerenkov Procurement |  | 335d | 2012-04-27 A | 2013-08-30 A | 14323000M | 100% |  | 2012-04-27 | 2013-08-29 |  |  |  | PROCUREMENT<$50K 60 NO ESCALATION FY13 | 53,246.97 |  | 53246.97 | FENKER H | 1 | 1 |  | U | HOWARD F | 09-022 | 10-069 | 11-026 | 11-046 |  |  | 08-016 |  | 09-012 |  | 42597.576 | 0 | 53246.97 | 5324697 | 100 |  |  |  |  |  | 12-053 |  |  |  |  |  |  |  |  |  |  |  |  |  |
| 143238P1LOEa |  | P-1 Supervise Constrctn of Noble Gas Cerenkov FY13 |  | 80d | 2012-10-01 A | 2013-01-31 A | 143238P1LOE | 100% |  |  |  |  |  |  | SCIENTIST [47.94 h] | 3,492.91 | 3,492.91 | 3492.9084 | FENKER H | 1 | 1 |  | E | HOWARD F | 09-022 | 10-069 | 11-026 | 11-046 | 143238P1LOEa |  |  |  |  | XX | 0 |  |  |  |  |  | 26.25 | 73.75 | 100 | 100 | 12-053 | 13-006F |  |  |  |  |  |  |  |  |  |  |  |  |
| 143238P1LOEb |  | P-2 Supervise Constrctn of Noble Gas Cerenkov |  | 168d | 2013-02-01 A | 2013-08-30 A | 143238P1LOEa | 100% |  | 2013-03-01 | 2013-10-25 |  |  |  | SCIENTIST [98.67 h] | 7,214.99 | 7,189.1 | 7189.0962 | FENKER H | 1 | 1 |  | E | HOWARD F |  |  |  |  |  |  |  |  |  |  | 2040.08 |  |  |  |  |  | 11.9047619 | 88.09523809 | 100 | 100 |  | 13-006 |  |  |  |  |  |  |  |  |  |  |  |  |
| 14323015 |  | Detailing Cerenkov-to-Magnet Interface |  | 130d | 2013-04-08 A | 2013-06-17 A | 14323010 FS-80d | 100% |  | 2014-02-10 | 2014-08-13 |  |  |  | MECH DES [200 h]; MECH ENG [80 h] | 16,233.6 | 15,730.8 | 15730.8 | FENKER H | 1 | 1 |  | H | HOWARD F |  |  |  |  |  |  |  |  |  |  | 0 |  |  |  |  |  |  |  |  |  |  | 13-006 |  |  |  |  |  |  |  |  |  |  |  |  |
| 14323020 |  | Re-Baseline Actuals Adjustment |  | 1d | 2013-08-30 A | 2013-08-30 A |  | 100% |  | 2013-09-03 | 2013-09-03 |  |  |  | PROCUREMENT>$50K 69 NO ESCALATION | -44,101.9 |  |  |  |  |  |  |  |  |  |  |  |  |  |  |  |  |  |  |  |  |  |  | 100 | ADJ |  |  |  |  |  |  |  |  |  |  |  |  |  |  |  |  |  |  |
| 24323005b |  | Fab Noble Gas Cerenkov Procurement |  | 225d | 2013-09-03 A | 2014-07-31 | 9-130M FS+228d | 20% | 182d |  |  | 264d | 220d | 8/5 M-F w/JLAB Holidays ReBaseline | PROCUREMENT>$50K 69 NO ESCALATION; PROCUREMENT<$50K 60 NO ESCALATION | 111,881.18 |  | 0 | FENKER H | 1 | 1 |  | D | HOWARD F | 09-022 | 10-069 | 11-026 | 11-046 |  |  | 08-016 |  | 09-012 |  |  | 89504.944 | 22376.236 | 2237623.6 | 100 |  |  |  |  |  | 12-053 | 13-006F | OPEN OBLIGATION | 24323005b | 22376.236 | OB | 13-015 | PR | OB |  |  |  |  |  |
| 24323012 |  | Build Vacuum Box |  | 62d | 2013-09-03 A | 2013-11-27 | 9-130M FS+228d |  | 19d |  |  | 462d | 436d | 8/5 M-F w/JLAB Holidays ReBaseline | PROCUREMENT<$50K 60 NO ESCALATION FY14 | 13,108.81 |  | 0 | FENKER H | 1 | 1 |  | D | HOWARD F | 09-022 | 10-069 | 11-026 | 11-046 |  |  | 08-016 |  | 09-012 |  |  | 13108.81 | 0 | 0 | 100 |  |  |  |  |  |  | 13-006F | OPEN OBLIGATION | 24323012 |  | EJ | 13-015 | PR | OB | EJ | Review |  |  |  |
| 243238P1LOEb |  | P-2 Supervise Constrctn of Noble Gas Cerenkov |  | 20d | 2013-09-03 A | 2013-09-30 A | 9-130M FS+228d | 100% |  | 2013-10-01 | 2013-10-28 |  |  | 8/5 M-F w/JLAB Holidays ReBaseline | SCIENTIST [13.33 h] | 1,002.15 | 971.22 | 0 | FENKER H | 1 | 1 |  | E | HOWARD F |  |  |  |  |  |  |  |  |  |  |  |  |  |  |  |  |  |  |  |  |  | 13-006 |  | 243238P1LOEb | 971.2238 |  | 13-015 | PR |  | PE |  |  |  |  |
| 24323025 |  | Install NGC Gas Mixer in Gas Shed |  | 20d | 2013-11-01 | 2013-12-02 | 9-140M FS+23d |  |  |  |  | 461d | 435d | 8/5 M-F w/JLAB Holidays ReBaseline | MECH TECH [80 h] | 3,785.6 |  | 0 | FENKER H | 1 | 1 |  | H | HOWARD F |  |  |  |  |  |  |  |  |  |  |  |  |  |  |  |  |  |  |  |  |  | 13-006 |  | 24323025 |  |  | 13-015 | PR |  | EJ |  | 14-001 |  |  |
|  | 4 | **1.4.3.2.4 HEAVY GAS CERENKOV** |  |  | 2011-05-06 | 2014-07-30 |  |  |  |  |  |  |  |  |  |  |  |  |  |  |  |  |  |  |  |  |  |  |  |  |  |  |  |  |  |  |  |  |  |  |  |  |  |  |  |  |  |  |  |  |  |  |  |  |  |  |  |  |
| 14324000 |  | Engineering & Design Oversite FY11 |  | 253.18d | 2011-05-06 A | 2012-05-14 A | 9-110M FS+165d | 100% |  |  |  |  |  |  | MECH DES [117.73 h]; MECH ENG [117.73 h] | 13,750.98 | 13,750.98 | 13495.3899 | FENKER H | 1 | 1 |  | S | HOWARD F | 09-022 | 10-069 | 11-026 | 11-046 |  |  | 08-016 | ST | 09-012 |  | 0 |  |  |  |  |  |  |  |  |  |  |  |  |  |  |  |  |  |  |  |  |  | 12-001 |  |
| 14324000a |  | Engineering & Design Oversite FY12 |  | 254d | 2011-05-06 A | 2012-05-14 A | 14324000 FS-60d | 100% |  |  |  |  |  |  | MECH DES [82.27 h]; MECH ENG [82.27 h] | 9,609.62 | 9,609.62 | 9731.7183 | FENKER H | 1 | 1 |  | S | HOWARD F | 09-022 | 10-069 | 11-026 | 11-046 |  |  | 08-016 | ST | 09-012 |  | 0 |  |  |  |  |  |  |  |  |  |  |  |  |  |  |  |  |  |  |  |  |  | 12-001 |  |
| 14324001 |  | Engineering & Design - Gas System FY11 |  | 302d | 2011-08-01 A | 2012-10-15 A | 9-110M FS+165d | 100% |  |  |  |  |  |  | MECH DES [208.8 h]; MECH ENG [104.4 h]; SCIENTIST [104.4 h] | 24,667.4 | 24,667.4 | 23984.856 | FENKER H | 1 | 1 |  | S | HOWARD F | 09-022 | 10-069 | 11-026 | 11-046 | 14324001 |  | 08-016 | ST | 09-012 |  | 0 |  |  |  |  |  |  |  |  |  |  | 13-006F |  |  |  |  |  |  |  |  |  |  | 12-001 |  |
| 14324001a |  | Engineering & Design - Gas System FY12 |  | 301.69d | 2011-08-01 A | 2012-10-15 A | 14324001 FS-120d | 100% |  |  |  |  |  |  | MECH DES [191.2 h]; MECH ENG [95.6 h]; SCIENTIST [95.6 h] | 22,587.35 | 22,587.35 | 22663.892 | FENKER H | 1 | 1 |  | S | HOWARD F | 09-022 | 10-069 | 11-026 | 11-046 | 14324001a |  | 08-016 | ST | 09-012 |  | 0 |  |  |  |  |  |  |  |  |  |  | 13-006F |  |  |  |  |  |  |  |  |  |  | 12-001 |  |
| 14324010 |  | Ship and Aluminize Mirrors |  | 198d | 2011-11-01 A | 2012-08-20 A | 9-120M | 100% |  |  |  |  |  |  | PROCUREMENT<$50K 60 NO ESCALATION FY13 | 19,166.72 |  | 19166.72 | FENKER H | 1 | 1 |  | H | HOWARD F | 09-022 | 10-069 | 11-026 | 11-046 |  |  | 08-016 |  | 09-012 |  | 0 | 0 | 19166.72 | 1916672 | 100 |  |  |  |  |  |  |  |  |  |  |  |  |  |  |  |  |  |  |  |
| 143248P1LOE |  | P-1 Supervise Constrctn of Heavy Gas Cerenkov FY12 |  | 186.63d | 2012-01-05 A | 2012-09-28 A | 14324000a FS-50d, 9-120M FS+60d, 122324015 | 100% |  |  |  |  |  |  | SCIENTIST [112.06 h] | 7,912.56 | 7,912.56 | 7912.5566 | FENKER H | 1 | 1 |  | E | HOWARD F | 09-022 | 10-069 | 11-026 | 11-046 |  |  |  |  |  |  | 0 |  |  |  |  |  | 37.07865168 | 62.92134831 | 100 | 100 | 12-053 |  |  |  |  |  |  |  |  |  |  |  |  |  |
| 14324003 |  | Fab Gas System Original |  | 4d | 2012-02-01 A | 2012-02-06 A | 14324001a | 100% |  |  |  |  |  |  | MECH TECH [20 h]; MECH DES [6.67 h] | 1,210.09 | 1,210.09 | 1210.0939 | FENKER H | 1 | 1 |  | S | HOWARD F | 09-022 | 10-069 | 11-026 | 11-046 |  |  | 08-016 | ST | 09-012 |  | 0 |  |  |  |  |  |  |  |  |  |  |  |  |  |  |  |  |  |  |  |  |  |  | 12-022 |
| 14324003a |  | Reverse Entry per CR12-022 |  | 4d | 2012-02-01 A | 2012-02-06 A | 9-120M FS+80d | 100% |  |  |  |  |  |  | MECH TECH [-20 h]; MECH DES [-6.67 h] | -1,210.09 | -1,210.09 |  | FENKER H | 1 | 1 |  | S | HOWARD F | 09-022 | 10-069 | 11-026 | 11-046 |  |  | 08-016 | ST | 09-012 |  |  |  |  |  |  |  |  |  |  |  |  |  |  |  |  |  |  |  |  |  |  |  |  | 12-022 |
| 143248P1LOE5 |  | P-1 Supervise Constrctn of Heavy Gas Cerenkov FY13 |  | 80d | 2012-10-01 A | 2013-01-31 A | 143248P1LOE | 100% |  |  |  |  |  |  | SCIENTIST [47.94 h] | 3,492.91 | 3,492.91 | 3492.9084 | FENKER H | 1 | 1 |  | E | HOWARD F | 09-022 | 10-069 | 11-026 | 11-046 | 143248P1LOE5 |  |  |  |  | XX | 0 |  |  |  |  |  | 26.25 | 73.75 | 100 | 100 | 12-053 |  |  |  |  |  |  |  |  |  |  |  |  |  |
| 14324003b |  | Fab Gas System Revised per CR12-022-- Procurement |  | 60d | 2013-04-01 A | 2013-08-30 A | 14324001a, 9-130M FS+100d | 100% |  | 2013-05-01 | 2013-07-25 |  |  |  | MECH DES [200 h]; PROCUREMENT<$50K 60; MECH TECH | 92,350.9 | 9,942 | 92350.9 | FENKER H | 1 | 1 |  | S | HOWARD F | 09-022 | 10-069 | 11-026 | 11-046 | 14324003b |  | 08-016 | ST | 09-012 |  | 32322.815 | 0 | 82408.9 | 8240890 | 100 |  |  |  |  |  |  | 13-006 |  |  |  |  |  |  |  |  |  |  |  | 12-022 |
| 14324005 |  | ASSEMBLE Gas System |  | 147d | 2013-08-27 A | 2013-08-30 A | 14324003b | 100% |  | 2013-08-27 | 2014-04-03 |  |  |  | MECH TECH [185.03 h] | 8,711.51 | 8,485.48 | 8485.4758 | FENKER H | 1 | 1 |  | S | HOWARD F | 09-022 | 10-069 | 11-026 | 11-046 |  |  | 08-016 | ST | 09-012 |  | 18344 |  |  |  |  |  |  |  |  |  |  | 13-006 |  |  |  |  |  |  |  |  |  |  |  | 12-022 |
| 14324015 |  | Re-Baseline Actuals Adjustment |  | 1d | 2013-08-30 A | 2013-08-30 A |  | 100% |  | 2013-09-03 | 2013-09-03 |  |  |  | PROCUREMENT>$50K 69 NO ESCALATION | -81,154.79 |  |  |  |  |  |  |  |  |  |  |  |  |  |  |  |  |  |  |  |  |  |  | 100 | ADJ |  |  |  |  |  |  |  |  |  |  |  |  |  |  |  |  |  |  |
| 24324005 |  | Assemble HGC Gas System & Leak-check tank |  | 20d | 2014-07-02 | 2014-07-30 | 9-140M FS+185d |  |  |  |  | 282d | 0d | 8/5 M-F w/JLAB Holidays ReBaseline | MECH TECH [320 h] | 15,142.4 |  | 0 | FENKER H | 1 | 1 |  | S | HOWARD F | 09-022 | 10-069 | 11-026 | 11-046 |  |  | 08-016 | ST | 09-012 |  |  |  |  |  |  |  |  |  |  |  |  | 13-006 |  | 24324005 |  |  | 13-015 | PR |  | PE |  | 14-001 |  | 12-022 |

Notes:
- 14322010: Explanation: Howard will Get a Progress tracking Sheet.
- 14322015: Explanation: Howard will Get a Progress tracking Sheet.
- 14323010: Steps: Preliminary Design (done); Final Design of Tank & Supports (done); Vacuum Shutter Design (done); Procurement Prep (done); Fabrication (done); window spool fabrication (done)
- 14324000: Steps: Preliminary Design & Q/A Requirements (done); Final Design Review (done); Jlab Safety & Q/A Review (done); Design documents filed at Jlab (done)
- 14324000a: Steps: Preliminary Design & Q/A Requirements (done); Final Design Review (done); Jlab Safety & Q/A Review (done); Design documents filed at Jlab (done)
- 14324001: Steps: Refine Conceptual Design (done); Preliminary Design & Q/A Requirements (done); Final Design (done); Jlab Safety & Q/A Review (done); Design documents filed at Jlab (done)
- 14324001a: Steps: Refine Conceptual Design (done); Preliminary Design & Q/A Requirements (done); Final Design (done); Jlab Safety & Q/A Review (done); Design documents filed at Jlab (done)
- 14324003: Steps: Procurement Prep - long lead-time (done); Procurement Prep - short lead-time (done); 50% Parts Delivered (done); 90% Parts Delivered (done); Plumbing Assembly (done); Controls Assembly (done); System Assembly (done)
- 14324003a: Explanation: "S" History change of 2 Days per CR 12-022 PMK / 2/10/12 / Steps: Reverse Entry per CR12-022 (done)
- 14324003b: Explanation: "S" History change of 2 Days per CR 12-022 PMK / 2/10/12 / Steps: Plumbing Assembly (done); Controls Assembly (done); System Assembly (done); Procurement Prep - long lead-time (done); Procurement Prep - short lead-time (done); 50% Parts Delivered (done); 90% Parts Delivered (done)
- 14324005: Explanation: "S" History change of 2 Days per CR 12-022 PMK / 2/10/12 / Steps: Leak-check HGC Vacuum Tank (done); Assemble HGC Gas System Piping (done); Test & Leak Check entire HGC Gas System in shop (done)
- 24324005: Explanation: "S" History change of 2 Days per CR 12-022 PMK / 2/10/12 / Steps: Assemble HGC Gas System Piping; Test & Leak-Check entire HGC Gas System in shop

| ID | WBS | Activity | Duration | Start | Finish | Predecessors | Complete | Remaining | Planned start | Planned finish | Total float | Free float | Calendar | Resources | Cost | Actual cost | MONTHLY EV COST | RESP - Responsibility | STRT%COMP for CM EVM | FNSH%COMP for CM EVM | CR 07-024 | EVMS Reporting Codes | CAM RESPONSIBLE | CR 09-012 | CR 10-069 | CR 11-026 | CR 11-046 | Remaining Material Cost Based on % Compl | Claimed Material Cost Based on % Complet | Initial Claimed Material Calc | Claimed Material Divider | Calculated Remaining Total Cost | Profile change | CR 09-022 | CR 11-025 | CR 12-014 | CR 12-047 | CR 12-012 | Specification | ReBaseline Actuals Adjustment | BOE NOTES | Original Activity ID Rebaseline | BOE Procurement | CR 13-015 | Post Rebaseline | Obligated Prior to Rebaseline | CR 13-006 | BOE Labor | CR 14-001 | 12 GEV MAJOR PROCUREMENT CATAGORY | CR 10-057 | CR 08-016 | Activities with Steps | CR 12-053 | CR 12-055 | MARCH!!! |
| --- | --- | --- | --- | --- | --- | --- | --- | --- | --- | --- | --- | --- | --- | --- | --- | --- | --- | --- | --- | --- | --- | --- | --- | --- | --- | --- | --- | --- | --- | --- | --- | --- | --- | --- | --- | --- | --- | --- | --- | --- | --- | --- | --- | --- | --- | --- | --- | --- | --- | --- | --- | --- | --- | --- | --- | --- |
|  | 5 | **1.4.3.2.5 SHOWER COUNTER** |  | 2010-06-01 | 2014-02-04 |  |  |  |  |  |  |  |  |  |  |  |  |  |  |  |  |  |  |  |  |  |  |  |  |  |  |  |  |  |  |  |  |  |  |  |  |  |  |  |  |  |  |  |  |  |  |  |  |  |  |  |
| 14325005 |  | Buy Lead Glass Blocks (SHOWER COUNTER) | 21d | 2010-06-01 A | 2010-06-30 A | 9-120M, 122325020 | 100% |  | 2010-06-01 | 2010-06-29 |  |  |  |  |  |  | 0 | FENKER H | 1 | 1 | 07-024 | Z | HOWARD F | 09-012 | 10-069 | 11-026 | 11-046 |  |  |  |  |  |  |  |  |  |  |  |  |  |  |  |  |  |  |  |  |  |  |  |  |  |  |  |  |  |
| 14325010 |  | Buy PMTs & Bases (SHOWER COUNTER) | 22d | 2010-06-01 A | 2010-06-30 A | 14325005 | 100% |  |  |  |  |  |  |  |  |  | 0 | FENKER H | 1 | 1 | 07-024 | Z | HOWARD F | 09-012 | 10-069 | 11-026 | 11-046 |  |  |  |  |  |  |  |  |  |  |  |  |  |  |  |  |  |  |  |  |  |  |  |  |  |  |  |  |  |
| 14325027 |  | Procure F250 ADCs (SHOWER COUNTER) | 200d | 2012-01-03 A | 2012-10-15 A | 9-120M FS+59d | 100% |  |  |  |  |  |  | PROCUREMENT<$50K 60 NO ESCALATION; PROCUREMENT>$50K 69 NO ESCALATION | 74,378.41 |  | 74378.41 | FENKER H | 1 | 1 | 07-024 | D | HOWARD F |  | 10-069 | 11-026 |  | 0 | 74378.41 | 7437841 | 100 | 0 | C | 09-022 | 11-025 | 12-014 | 12-047F |  |  |  |  |  |  |  |  |  |  |  |  |  |  |  |  |  |  |  |
| 14325027b |  | Procure TI for Calorimeter Ref. Hall D 1543040 | 211d | 2012-01-16 A | 2012-11-12 A | 9-110M FS+231d, 9-120M FS+65d | 100% |  | 2012-01-17 | 2012-11-12 |  |  |  | PROCUREMENT<$50K 60 NO ESCALATION FY12 | 1,850 |  | 1850 | FENKER H | 1 | 1 | 07-024 | H | HOWARD F | 09-012 | 10-069 | 11-026 | 11-046 | 0 | 1850 | 185000 | 100 | 0 | C | 09-022 | 11-025 |  |  | 12-012 |  |  |  |  |  |  |  |  |  |  |  |  |  |  |  |  |  |  |
| 14325027c |  | Procure SD for Calorimeter Ref. Hall D 1543055 | 180d | 2012-02-01 A | 2012-10-15 A | 9-120M FS+90d, 9-110M FS+161d | 100% |  |  |  |  |  |  | PROCUREMENT<$50K 60 | 2,500 |  | 2500 | FENKER H | 1 | 1 | 07-024 | D | HOWARD F | 09-012 | 10-069 | 11-026 | 11-046 | 0 | 2500 | 250000 | 100 | 0 | C | 09-022 | 11-025 |  |  |  |  |  |  |  |  |  |  |  |  |  |  |  |  |  |  |  |  |  |
| 14325027a |  | Procure CTP for Calorimeter Ref. Hall D 1543025 | 217d | 2012-09-17 A | 2013-08-30 A | 9-130M, 9-110M FS+190d, 9-120M FS+185d | 100% |  | 2012-09-17 | 2013-08-01 |  |  |  | PROCUREMENT<$50K 60 | 5,000 |  | 5000 | FENKER H | 1 | 1 | 07-024 | D | HOWARD F | 09-012 | 10-069 | 11-026 | 11-046 | 0 | 5000 | 500000 | 100 | 5000 | C | 09-022 | 11-025 |  |  |  |  |  |  |  |  |  |  |  |  |  |  |  |  |  |  |  |  |  |
| 14325028 |  | UMASS - Testing of F250 ADCs by University (SHOWER COUNTER) REFERENCE 1541057 | 130d | 2012-09-17 A | 2013-01-28 A | 14325027 FS-40d | 100% |  | 2012-09-17 | 2013-03-29 |  |  |  | PROCUREMENT<$50K 60 NO ESCALATION | 5,000 |  | 5000 | FENKER H | 1 | 1 | 07-024 | P | HOWARD F | 09-012 | 10-069 | 11-026 |  | 0 | 5000 | 500000 | 100 | 0 | C | 09-022 | 11-025 | 12-014 | 12-047 | 12-012 |  |  |  |  |  |  |  |  |  |  |  |  |  |  |  |  |  |  |
| 14325015 |  | Fab Supprt Sys (SHOWER COUNTER) | 10d | 2013-04-08 A | 2013-05-13 A | 14325005, 14363030a FS-100d, 14363030 FS-40d | 100% |  | 2013-09-20 | 2013-10-03 |  |  |  |  |  |  | 0 | FENKER H | 1 | 1 | 07-024 | Z | HOWARD F | 09-012 | 10-069 | 11-026 | 11-046 |  |  |  |  |  |  | 09-022 | 11-025 |  |  |  | 14325015 |  |  |  |  |  |  |  |  |  |  |  |  |  |  |  |  |  |
| 14325030 |  | Re-Baseline Actuals Adjustment | 1d | 2013-08-30 A | 2013-08-30 A |  | 100% |  | 2013-09-03 | 2013-09-03 |  |  |  | PROCUREMENT>$50K 69 NO ESCALATION | -8,734.67 |  |  |  |  |  |  |  |  |  |  |  |  |  |  |  | 100 |  |  |  |  |  |  |  |  | ADJ |  |  |  |  |  |  |  |  |  |  |  |  |  |  |  |  |
| 24325027a |  | Procure CTP for Calorimeter Ref. Hall D 1543025 | 20d | 2013-09-03 A | 2013-12-02 | 9-130M FS+228d |  | 20d | 2013-09-03 | 2013-09-30 | 358d | 117d | 8/5 M-F w/JLAB Holidays ReBaseline | PROCUREMENT<$50K 60 | 4,502.29 |  | 0 | FENKER H | 1 | 1 | 07-024 | D | HOWARD F | 09-012 | 10-069 | 11-026 | 11-046 | 4502.29 | 0 | 0 | 100 |  | C | 09-022 | 11-025 |  |  |  |  |  | OPEN OBLIGATION | 24325027a | OB | 13-015 | PR | OB |  |  |  |  |  |  |  |  |  |  |
| 24325030 |  | Fiducialize SHMS Shower Counter (Frame) | 57d | 2013-11-01 | 2014-02-04 | 9-140M |  |  |  |  | 319d | 40d | 8/5 M-F w/JLAB Holidays ReBaseline | MECH TECH [16 h] | 757.12 |  | 0 | FENKER H | 1 | 1 |  | H | HOWARD F |  |  |  |  |  |  |  |  |  |  |  |  |  |  |  |  |  |  | 24325030 |  | 13-015 | PR |  | 13-006 | PE | 14-001 |  |  |  |  |  |  |  |
|  | 6 | **1.4.3.2.6 AEROGEL CERENKOV** |  |  |  |  |  |  |  |  |  |  |  |  |  |  |  |  |  |  |  |  |  |  |  |  |  |  |  |  |  |  |  |  |  |  |  |  |  |  |  |  |  |  |  |  |  |  |  |  |  |  |  |  |  |  |
|  | 7 | **1.4.3.2.7 TRD** |  |  |  |  |  |  |  |  |  |  |  |  |  |  |  |  |  |  |  |  |  |  |  |  |  |  |  |  |  |  |  |  |  |  |  |  |  |  |  |  |  |  |  |  |  |  |  |  |  |  |  |  |  |  |
|  | 8 | **1.4.3.2.8 DETECTOR FRAME** |  | 2010-06-01 | 2014-06-20 |  |  |  |  |  |  |  |  |  |  |  |  |  |  |  |  |  |  |  |  |  |  |  |  |  |  |  |  |  |  |  |  |  |  |  |  |  |  |  |  |  |  |  |  |  |  |  |  |  |  |  |
| 14328015 |  | Procure Support Frame | 88d | 2010-06-01 A | 2010-10-04 A | 9-100M FS+162d | 100% |  |  |  |  |  |  | PROCUREMENT<$50K 60 | 28,000 |  | 28000 | FENKER H | 1 | 1 |  | D | HOWARD F |  | 10-069 | 11-026 | 11-046 | 0 | 28000 | 2800000 | 100 | 0 |  |  |  |  |  |  |  |  |  |  |  |  |  |  |  |  |  | 4315 | 10-057 |  |  |  |  |  |
| 14328010 |  | Fab Supprt for individual Detctr's FY12 | 465d | 2011-05-09 A | 2012-12-17 A | 122325020 | 100% |  | 2011-05-09 | 2013-03-25 |  |  |  | MECH ENG [119.21 h]; MECH DES [238.41 h]; MECH TECH [298.01 h]; MSHOP | 37,624.26 | 32,968.94 | 37584.7093 | FENKER H | 1 | 1 |  | S | HOWARD F | 09-012 | 10-069 | 11-026 | 11-046 |  |  |  |  | 0 |  | 09-022 |  |  |  |  | 14328010 |  |  |  |  |  |  |  |  |  |  |  |  | 08-016 | ST | 12-053 |  |  |
| 14328010a |  | Fab Supprt for individual Detctr's FY13 | 465d | 2011-05-09 A | 2012-12-17 A | 14328010 FS-100d | 100% |  | 2011-05-09 | 2013-03-25 |  |  |  | MECH DES [81.59 h]; MECH TECH [101.99 h]; MSHOP; MECH ENG [40.79 h] | 12,924.74 | 11,282.77 | 13273.0547 | FENKER H | 1 | 1 |  | S | HOWARD F | 09-012 | 10-069 | 11-026 | 11-046 |  |  |  |  | 0 |  | 09-022 |  |  |  |  | 14328010a |  |  |  |  |  |  |  |  |  |  |  |  | 08-016 | ST | 12-053 |  |  |
| 14328010b |  | Fab Supprt for individual Detctr's Procurement Part A | 349d | 2011-05-09 A | 2012-09-28 A | 122325020 | 100% |  |  |  |  |  |  | PROCUREMENT<$50K 60 NO ESCALATION FY13 | 17,400 |  | 17400 | FENKER H | 1 | 1 |  | S | HOWARD F | 09-012 | 10-069 | 11-026 | 11-046 | 0 | 17400 | 1740000 | 100 | 0 |  | 09-022 |  |  |  |  |  |  |  |  |  |  |  |  |  |  |  |  |  | 08-016 | ST | 12-053 | 12-055 |  |
| 14328005 |  | Fab General Struct for Detector Frame FY12 | 329d | 2011-10-03 A | 2013-02-11 A | 122325020, 9-120M | 100% |  | 2011-10-03 | 2013-02-04 |  |  |  | SUPPLIES & MATERIALS; MECH ENG [110.2 h]; MECH TECH [367.35 h]; PLABOR; MSHOP; MECH DES [257.14 h]; TRAVEL | 70,994.57 | 36,740.43 | 70704.3318 | FENKER H | 1 | 1 |  | S | HOWARD F | 09-012 | 10-069 | 11-026 | 11-046 |  |  |  |  | 0 |  |  |  |  |  |  | 14328005 |  |  |  |  |  |  |  |  |  |  |  |  | 08-016 | ST | 12-053 |  | XX |
| 14328005a |  | Fab General Struct for Detector Frame FY13 | 329d | 2011-10-03 A | 2013-02-11 A | 14328005 FS-45d | 100% |  | 2011-10-03 | 2013-02-04 |  |  |  | MECH ENG [9.8 h]; MECH TECH [32.65 h]; PLABOR; MSHOP; MECH DES [22.86 h]; TRAVEL; SUPPLIES & MATERIALS | 6,408.09 | 3,266.27 | 6485.8076 | FENKER H | 1 | 1 |  | S | HOWARD F | 09-012 | 10-069 | 11-026 | 11-046 |  |  |  |  | 0 |  |  |  |  |  |  | 14328005a |  |  |  |  |  |  |  |  |  |  |  |  | 08-016 | ST | 12-053 |  | XX |
| 14328005b |  | Fab General Struct for Detector Frame Procurement Part A | 329d | 2011-10-03 A | 2013-02-11 A | 122325020, 9-120M | 100% |  | 2011-10-03 | 2013-02-04 |  |  |  | PROCUREMENT>$50K 69 NO ESCALATION FY13; PROCUREMENT<$50K 60 NO ESCALATION FY13 | 177,820.34 |  | 177820.34 | FENKER H | 1 | 1 |  | S | HOWARD F | 09-012 | 10-069 | 11-026 | 11-046 | 0 | 177820.34 | 17782034 | 100 | 0 |  |  |  |  |  |  |  |  |  |  |  |  |  |  |  |  |  |  |  | 08-016 | ST | 12-053 | 12-055 | XX |
| 14328010ba |  | Fab Supprt for individual Detctr's Procurement Part B | 115d | 2013-04-01 A | 2013-08-30 A | 9-130M FS+80d, 122325020 | 100% |  | 2013-05-01 | 2013-10-11 |  |  |  | PROCUREMENT<$50K 60 NO ESCALATION FY13 | 25,948.72 |  | 25948.72 | FENKER H | 1 | 1 |  | S | HOWARD F | 09-012 | 10-069 | 11-026 | 11-046 | 0 | 25948.72 | 2594872 | 100 | 12974.36 |  | 09-022 |  |  |  |  |  |  |  |  |  |  |  |  |  |  |  |  |  | 08-016 | ST | 12-053 | 12-055 |  |
| 14328005ba |  | Fab General Struct for Detector Frame Procurement Part B | 39d | 2013-06-01 A | 2013-08-26 A | 9-120M, 122325020, 9-130M FS+50d | 100% |  | 2013-07-01 | 2013-08-23 |  |  |  | PROCUREMENT>$50K 69 NO ESCALATION FY13 | 8,000 |  | 8000 | FENKER H | 1 | 1 |  | D | HOWARD F | 09-012 | 10-069 | 11-026 | 11-046 | 0 | 8000 | 800000 | 100 | 2000 |  |  |  |  |  |  |  |  |  |  |  |  |  |  |  |  |  |  |  | 08-016 |  | 12-053 | 12-055 | XX |
| 14328020 |  | Re-Baseline Actuals Adjustment | 1d | 2013-08-30 A | 2013-08-30 A |  | 100% |  | 2013-09-03 | 2013-09-03 |  |  |  | PROCUREMENT>$50K 69 NO ESCALATION | -213,887.2 |  |  |  |  |  |  |  |  |  |  |  |  |  |  |  | 100 |  |  |  |  |  |  |  |  | ADJ |  |  |  |  |  |  |  |  |  |  |  |  |  |  |  |  |
| 24328005 |  | Calorimeter Support Frame TBP | 43d | 2013-09-03 A | 2013-12-20 | 9-130M FS+228d |  | 34d | 2013-09-03 | 2013-10-31 | 373d | 81d | 8/5 M-F w/JLAB Holidays ReBaseline | PROCUREMENT<$50K 60 NO ESCALATION FY14 | 15,150 |  | 0 | FENKER H | 1 | 1 |  | D | HOWARD F | 09-012 | 10-069 | 11-026 | 11-046 | 15150 | 0 | 0 | 100 |  |  |  |  |  |  |  |  |  |  | 24328005 | OB | 13-015 | PR | OB | 13-006F |  |  |  |  | 08-016 |  | 12-053 |  |  |
| 24328010ba |  | Fab Supprt for individual Detctr's Procurement Part B | 119d | 2014-01-03 | 2014-06-20 | 9-140M FS+60d, 24328005 FS-80d |  |  |  |  | 292d | 248d | 8/5 M-F w/JLAB Holidays ReBaseline | PROCUREMENT<$50K 60 | 31,141.06 |  | 0 | FENKER H | 1 | 1 |  | D | HOWARD F | 09-012 | 10-069 | 11-026 | 11-046 | 31141.06 | 0 | 0 | 100 |  |  | 09-022 |  |  |  |  |  |  |  | 24328010ba | EJ | 13-015 | PR |  | 13-006F |  | 14-001 |  |  | 08-016 |  | 12-053 | 12-055 |  |

Notes:
- 14325027: Corrective Actions: TEMPORARY INPUT FROM ANTJE, BUT WILL HAVE TO BE COMPENSATED BY REDUCTIONS / FROM ELKE
- 14325027b: Corrective Actions: TEMPORARY INPUT FROM ANTJE, BUT WILL HAVE TO BE COMPENSATED BY REDUCTIONS / FROM ELKE
- 14325027c: Corrective Actions: TEMPORARY INPUT FROM ANTJE, BUT WILL HAVE TO BE COMPENSATED BY REDUCTIONS / FROM ELKE
- 14325027a: Corrective Actions: TEMPORARY INPUT FROM ANTJE, BUT WILL HAVE TO BE COMPENSATED BY REDUCTIONS / FROM ELKE
- 14325028: Corrective Actions: TEMPORARY INPUT FROM ANTJE, BUT WILL HAVE TO BE COMPENSATED BY REDUCTIONS / FROM ELKE
- 24325027a: Corrective Actions: TEMPORARY INPUT FROM ANTJE, BUT WILL HAVE TO BE COMPENSATED BY REDUCTIONS / FROM ELKE
- 14328010: Steps: Detail manufacturing drawings for S1XY supports (done); Detail manufacturing drawings for Drift Chamber supports (done); Detail manufacturing drawings for HGC supports (done); Detail manufacturing drawings for S2X supports (done); Detail manufacturing drawings for NGC supports (done); Review 5 as-built assemblies (done); Q/A Check of 5 as-built assemblies (done); Procure rigging fixtures (done)
- 14328010a: Steps: Detail manufacturing drawings for S1XY supports (done); Detail manufacturing drawings for Drift Chamber supports (done); Detail manufacturing drawings for HGC supports (done); Detail manufacturing drawings for S2X supports (done); Detail manufacturing drawings for NGC supports (done); Review 5 as-built assemblies (done); Q/A Check of 5 as-built assemblies (done); Procure rigging fixtures (done)
- 14328010b: Steps: Detail manufacturing drawings for S1XY supports (done); Detail manufacturing drawings for Drift Chamber supports (done); Detail manufacturing drawings for HGC supports (done); Detail manufacturing drawings for S2X supports (done)
- 14328005: Steps: Prepare 3D Model (done); Produce Manuf. Drawings - Front Sect (done); Produce Manuf. Drawings - Mid Sect (done); Produce Manuf. Drawings - Rear Sect (done); Procurement Prep (done); Contract Start (done); Front Section Delivered (done); Mid Section Delivered (done); Rear Section Delivered (done)
- 14328005a: Steps: Prepare 3D Model (done); Produce Manuf. Drawings - Front Sect (done); Produce Manuf. Drawings - Mid Sect (done); Produce Manuf. Drawings - Rear Sect (done); Procurement Prep (done); Contract Start (done); Front Section Delivered (done); Mid Section Delivered (done); Rear Section Delivered (done)
- 14328005b: Steps: Prepare 3D Model (done); Produce Manuf. Drawings - Front Sect (done); Produce Manuf. Drawings - Mid Sect (done); Produce Manuf. Drawings - Rear Sect (done); Procurement Prep (done); Contract Start (done); Front Section Delivered (done); Mid Section Delivered (done); Rear Section Delivered (done)
- 14328010ba: Steps: Detail manufacturing drawings for NGC supports (done); Review Drawings (done); Q/A Check of 5 as-built assemblies (done); Procure rigging fixtures (done)

| ID | WBS | Activity | Duration | Start | Finish | Predecessors | Complete | Remaining | Planned start | Planned finish | Total float | Free float | Calendar | Resources | Cost | Actual cost | MONTHLY EV COST | ReBaseline Actuals Adjustment | Original Activity ID Rebaseline | Remaining Material Cost Based on % Compl | Claimed Material Cost Based on % Complet | Initial Claimed Material Calc | Claimed Material Divider | RESP - Responsibility | STRT%COMP for CM EVM | FNSH%COMP for CM EVM | EVMS Reporting Codes | CAM RESPONSIBLE | CR 10-069 | CR 11-025 | CR 11-026 | CR 11-046 | CR 12-022 | CR 13-006 | BOE Procurement | CR 13-015 | Post Rebaseline | CR 14-001 | Calculated Remaining Total Cost | CR 07-024 | CR 08-016 | CR 09-012 | CR 12-012 | CR 12-014 | Specification | Duplications | CR 12-053 | MARCH!!! | LOE % Pre Calc | LOE % | LOE Divider | LOE Multiplier | Activities with Steps | CR 12-054 | BOE Labor | Obligated Prior to Rebaseline |
| --- | --- | --- | --- | --- | --- | --- | --- | --- | --- | --- | --- | --- | --- | --- | --- | --- | --- | --- | --- | --- | --- | --- | --- | --- | --- | --- | --- | --- | --- | --- | --- | --- | --- | --- | --- | --- | --- | --- | --- | --- | --- | --- | --- | --- | --- | --- | --- | --- | --- | --- | --- | --- | --- | --- | --- | --- |
|  | 3 | **1.4.3.3 COMPUTING** |  | 2013-08-30 | 2014-12-02 |  |  |  |  |  |  |  |  |  |  |  |  |  |  |  |  |  |  |  |  |  |  |  |  |  |  |  |  |  |  |  |  |  |  |  |  |  |  |  |  |  |  |  |  |  |  |  |  |  |  |  |
|  | 1 | **1.4.3.3.1 DAQ** |  | 2013-08-30 | 2014-12-02 |  |  |  |  |  |  |  |  |  |  |  |  |  |  |  |  |  |  |  |  |  |  |  |  |  |  |  |  |  |  |  |  |  |  |  |  |  |  |  |  |  |  |  |  |  |  |  |  |  |  |  |
| 1433015 |  | Re-Baseline Actuals Adjustment | 1d | 2013-08-30 A | 2013-08-30 A |  | 100% |  | 2013-09-03 | 2013-09-03 |  |  |  | PROCUREMENT>$50K 69 NO ESCALATION |  |  | 0 | ADJ |  |  |  |  |  |  |  |  |  |  |  |  |  |  |  |  |  |  |  |  |  |  |  |  |  |  |  |  |  |  |  |  |  |  |  |  |  |  |
| 2433000 |  | Buy 5 Fast PC's for Data Acq & Processing (COMP) | 40d | 2014-10-06 | 2014-12-02 | 9-155M FS+3d |  |  |  |  | 186d | 0d | 8/5 M-F w/JLAB Holidays ReBaseline | PROCUREMENT<$50K 60 | 19,228.74 |  | 0 |  | 2433000 | 19228.74 | 0 | 0 | 100 | FENKER H | 1 | 1 | D | HOWARD F | 10-069 | 11-025 | 11-026 | 11-046 | 12-022 | 13-006 | PE | 13-015 | PR | 14-001 |  |  |  |  |  |  |  |  |  |  |  |  |  |  |  |  |  |  |
| 2433005 |  | Buy File Servers for Data Acq System (COMP) | 40d | 2014-10-06 | 2014-12-02 | 9-155M FS+3d |  |  |  |  | 186d | 0d | 8/5 M-F w/JLAB Holidays ReBaseline | PROCUREMENT<$50K 60 | 12,458.43 |  | 0 |  | 2433005 | 12458.43 | 0 | 0 | 100 | FENKER H | 1 | 1 | D | HOWARD F | 10-069 | 11-025 | 11-026 | 11-046 | 12-022 | 13-006 | PE | 13-015 | PR | 14-001 |  |  |  |  |  |  |  |  |  |  |  |  |  |  |  |  |  |  |
| 2433010 |  | Buy 8 Workstations/Monitors (COMP) | 40d | 2014-10-06 | 2014-12-02 | 9-155M FS+3d |  |  |  |  | 186d | 0d | 8/5 M-F w/JLAB Holidays ReBaseline | PROCUREMENT<$50K 60 | 12,458.43 |  | 0 |  | 2433010 | 12458.43 | 0 | 0 | 100 | FENKER H | 1 | 1 | D | HOWARD F | 10-069 | 11-025 | 11-026 | 11-046 | 12-022 | 13-006 | PE | 13-015 | PR | 14-001 |  |  |  |  |  |  |  |  |  |  |  |  |  |  |  |  |  |  |
|  | 2 | **1.4.3.3.2 SLOW CONTROLS** |  |  |  |  |  |  |  |  |  |  |  |  |  |  |  |  |  |  |  |  |  |  |  |  |  |  |  |  |  |  |  |  |  |  |  |  |  |  |  |  |  |  |  |  |  |  |  |  |  |  |  |  |  |  |
|  | 4 | **1.4.3.4 ELECTRONICS** |  | 2011-04-02 | 2014-02-10 |  |  |  |  |  |  |  |  |  |  |  |  |  |  |  |  |  |  |  |  |  |  |  |  |  |  |  |  |  |  |  |  |  |  |  |  |  |  |  |  |  |  |  |  |  |  |  |  |  |  |  |
|  | 1 | **1.4.3.4.1 FAST ELECTRONICS** |  | 2011-05-09 | 2014-02-10 |  |  |  |  |  |  |  |  |  |  |  |  |  |  |  |  |  |  |  |  |  |  |  |  |  |  |  |  |  |  |  |  |  |  |  |  |  |  |  |  |  |  |  |  |  |  |  |  |  |  |  |
| 14341007 |  | SOS Signal Cable Prepare for Installation (FAST Electrnc's) | 38d | 2011-05-09 A | 2011-06-30 A | 4A-01M | 100% |  |  |  |  |  |  | SUPPLIES & MATERIALS; ELEC TECH [400 h] | 27,427 | 17,108 | 27427 |  |  |  |  |  |  | FENKER H | 1 | 1 | H | HOWARD F | 10-069 |  |  | 11-046 |  |  |  |  |  |  | 0 | 07-024 | 08-016 | 09-012 |  |  |  |  |  |  |  |  |  |  |  |  |  |  |
| 14341010 |  | Proc Discriminators for Wire Chambers (FAST Electrnc's) | 4d | 2011-09-05 A | 2011-09-10 A | 9-120M FS+60d | 100% |  | 2011-09-06 | 2011-09-09 |  |  |  |  |  |  | 0 |  |  |  |  |  |  | FENKER H | 1 | 1 | Z | HOWARD F | 10-069 |  | 11-026 | 11-046 |  |  |  |  |  |  |  | 07-024 |  | 09-012 |  |  |  |  |  |  |  |  |  |  |  |  |  |  |
| 14341015 |  | Proc ADCs for Hodoscopes (FAST Electrnc's) | 200d | 2012-01-03 A | 2012-10-15 A | 9-120M FS+59d | 100% |  |  |  |  |  |  | PROCUREMENT<$50K 60 NO ESCALATION; PROCUREMENT>$50K 69 NO ESCALATION | 53,717.74 |  | 53717.74 |  |  | 0 | 53717.74 | 5371774 | 100 | FENKER H | 1 | 1 | D | HOWARD F | 10-069 |  | 11-026 | 11-046 |  |  |  |  |  |  | 0 | 07-024 | 08-016 | 09-012 | 12-012 | 12-014 |  |  |  |  |  |  |  |  |  |  |  |  |
| 14341005 |  | Proc TDCs for Wire Chambers (FAST Electrnc's) | 11d | 2012-01-09 A | 2012-01-24 A | 9-120M FS+60d | 100% |  |  |  |  |  |  |  |  |  | 0 |  |  |  |  |  |  | FENKER H | 1 | 1 | Z | HOWARD F | 10-069 |  | 11-026 | 11-046 |  |  |  |  |  |  |  | 07-024 | 08-016 | 09-012 |  |  |  |  |  |  |  |  |  |  |  |  |  |  |
| 14341020 |  | Proc ADCs for Calorimeter (FAST Electrnc's) FY12 | 180d | 2012-02-01 A | 2012-10-15 A | 9-120M FS+60d | 100% |  |  |  |  |  |  | SUPPLIES & MATERIALS | 1,625.48 |  | 1625.48 |  |  |  |  |  |  | FENKER H | 1 | 1 | D | HOWARD F | 10-069 |  | 11-026 | 11-046 |  |  |  |  |  |  | 0 | 07-024 | 08-016 | 09-012 |  |  | 14341020 | DUP | 12-053 |  |  |  |  |  |  |  |  |  |
| 14341020a |  | Proc ADCs for Calorimeter (FAST Electrnc's) FY13 | 180d | 2012-02-01 A | 2012-10-15 A | 14341020 FS-80d | 100% |  |  |  |  |  |  | SUPPLIES & MATERIALS | 520.24 |  | 520.24 |  |  |  |  |  |  | FENKER H | 1 | 1 | D | HOWARD F | 10-069 |  | 11-026 | 11-046 |  |  |  |  |  |  | 0 | 07-024 | 08-016 | 09-012 |  |  | 14341020a | DUP | 12-053 |  |  |  |  |  |  |  |  |  |
| 14341025 |  | Proc TDCs for Hodoscopes (FAST Electrnc's) | 9d | 2012-02-01 A | 2012-02-13 A | 9-120M FS+60d | 100% |  |  |  |  |  |  |  |  |  | 0 |  |  |  |  |  |  | FENKER H | 1 | 1 | Z | HOWARD F | 10-069 |  | 11-026 | 11-046 |  |  |  |  |  |  |  | 07-024 | 08-016 | 09-012 |  |  |  |  |  |  |  |  |  |  |  |  |  |  |
| 14341030 |  | Proc Discriminators for Hodoscopes (FAST Electrnc's) | 9d | 2012-02-01 A | 2012-02-13 A | 9-120M FS+60d | 100% |  |  |  |  |  |  |  |  |  | 0 |  |  |  |  |  |  | FENKER H | 1 | 1 | Z | HOWARD F | 10-069 |  | 11-026 | 11-046 |  |  |  |  |  |  |  | 07-024 | 08-016 | 09-012 |  |  |  |  |  |  |  |  |  |  |  |  |  |  |
| 14341035 |  | Proc HV for All Detctr's (FAST Electrnc's) | 9d | 2012-02-01 A | 2012-02-13 A | 9-120M FS+60d | 100% |  |  |  |  |  |  |  |  |  | 0 |  |  |  |  |  |  | FENKER H | 1 | 1 | Z | HOWARD F | 10-069 |  | 11-026 | 11-046 |  |  |  |  |  |  |  | 07-024 | 08-016 | 09-012 |  |  |  |  |  |  |  |  |  |  |  |  |  |  |
| 14341040 |  | Proc CAMAC Controller & Crate (FAST Electrnc's) | 9d | 2012-02-01 A | 2012-02-13 A | 9-120M FS+60d | 100% |  |  |  |  |  |  |  |  |  | 0 |  |  |  |  |  |  | FENKER H | 1 | 1 | Z | HOWARD F | 10-069 |  | 11-026 | 11-046 |  |  |  |  |  |  |  | 07-024 | 08-016 | 09-012 |  |  |  |  |  |  |  |  |  |  |  |  |  |  |
| 14341045 |  | Proc NIM Crates (FAST Electrnc's) | 9d | 2012-02-01 A | 2012-02-13 A | 9-120M FS+60d | 100% |  |  |  |  |  |  |  |  |  | 0 |  |  |  |  |  |  | FENKER H | 1 | 1 | Z | HOWARD F | 10-069 |  | 11-026 | 11-046 |  |  |  |  |  |  |  | 07-024 | 08-016 | 09-012 |  |  |  |  |  |  |  |  |  |  |  |  |  |  |
| 14341050 |  | Proc NIM & CAMAC Logic (FAST Electrnc's) | 9d | 2012-02-01 A | 2012-02-13 A | 9-120M FS+60d | 100% |  |  |  |  |  |  |  |  |  | 0 |  |  |  |  |  |  | FENKER H | 1 | 1 | Z | HOWARD F | 10-069 |  | 11-026 | 11-046 |  |  |  |  |  |  |  | 07-024 | 08-016 | 09-012 |  |  |  |  |  |  |  |  |  |  |  |  |  |  |
| 14341055 |  | Proc scalers (FAST Electrnc's) | 9d | 2012-02-01 A | 2012-02-13 A | 9-120M FS+60d | 100% |  |  |  |  |  |  |  |  |  | 0 |  |  |  |  |  |  | FENKER H | 1 | 1 | Z | HOWARD F | 10-069 |  | 11-026 | 11-046 |  |  |  |  |  |  |  | 07-024 | 08-016 | 09-012 |  |  |  |  |  |  |  |  |  |  |  |  |  |  |
| 14341065 |  | Proc VME Crates (FAST Electrnc's) REF. HallD 1544006 | 252d | 2012-02-01 A | 2013-01-31 A | 9-120M FS+60d | 100% |  | 2012-02-01 | 2013-02-05 |  |  |  | PROCUREMENT<$50K 60 | 10,648.18 |  | 10648.18 |  |  | 0 | 10648.18 | 1064818 | 100 | FENKER H | 1 | 1 | D | HOWARD F | 10-069 | 11-025 | 11-026 | 11-046 |  |  |  |  |  |  | 0 | 07-024 | 08-016 | 09-012 | 12-012 |  |  |  |  | XX |  |  |  |  |  |  |  |  |
| 14341070 |  | Proc High-Power 21-slot VME64x/VXS crate for DF2 | 252d | 2012-02-01 A | 2012-12-17 A | 9-120M FS+85d | 100% |  | 2012-02-01 | 2013-02-05 |  |  |  | PROCUREMENT<$50K 60 NO ESCALATION FY13 | 10,000 |  | 10000 |  |  | 0 | 10000 | 1000000 | 100 | FENKER H | 1 | 1 | D | HOWARD F | 10-069 |  | 11-026 | 11-046 |  |  |  |  |  |  | 0 | 07-024 | 08-016 | 09-012 | 12-012 |  |  |  |  |  |  |  |  |  |  |  |  |  |
| 14341115 |  | Recondition 1 existing VME64x crate (w/o VXS) FY12 | 252d | 2012-02-01 A | 2012-12-17 A | 9-120M FS+85d | 100% |  | 2012-02-01 | 2013-02-05 |  |  |  | ELEC ENG [42.74 h]; SCIENTIST [44.27 h] | 6,206.12 | 6,188.92 | 6141.6391 |  |  |  |  |  |  | FENKER H | 1 | 1 | D | HOWARD F | 10-069 |  | 11-026 | 11-046 |  |  |  |  |  |  | 0 | 07-024 | 08-016 | 09-012 | 12-012 |  | 14341115 |  | 12-053 |  |  |  |  |  |  |  |  |  |
| 14341115a |  | Recondition 1 existing VME64x crate (w/o VXS) FY13 | 252d | 2012-02-01 A | 2012-12-17 A | 14341115 FS-80d | 100% |  | 2012-02-01 | 2013-02-05 |  |  |  | ELEC ENG [13.26 h]; SCIENTIST [13.73 h] | 1,925.1 | 1,919.81 | 1965.8284 |  |  |  |  |  |  | FENKER H | 1 | 1 | D | HOWARD F | 10-069 |  | 11-026 | 11-046 |  |  |  |  |  |  | 0 | 07-024 | 08-016 | 09-012 | 12-012 |  |  |  | 12-053 |  |  |  |  |  |  |  |  |  |
| 14341095 |  | Proc 2 TI Modules for DF2 | 173d | 2012-03-12 A | 2012-11-12 A | 9-120M FS+85d | 100% |  |  |  |  |  |  | PROCUREMENT<$50K 60 NO ESCALATION FY13 | 6,450 |  | 6450 |  |  | 0 | 6450 | 645000 | 100 | FENKER H | 1 | 1 | D | HOWARD F | 10-069 |  | 11-026 | 11-046 |  |  |  |  |  |  | 0 | 07-024 | 08-016 | 09-012 | 12-012 |  |  |  |  |  |  |  |  |  |  |  |  |  |
| 14341097 |  | Proc TD Module for DF2 | 173d | 2012-03-12 A | 2012-11-12 A | 9-120M FS+85d | 100% |  |  |  |  |  |  | PROCUREMENT<$50K 60 NO ESCALATION FY13 | 5,100 |  | 5100 |  |  | 0 | 5100 | 510000 | 100 | FENKER H | 1 | 1 | D | HOWARD F | 10-069 |  | 11-026 | 11-046 |  |  |  |  |  |  | 0 | 07-024 | 08-016 | 09-012 | 12-012 |  |  |  |  |  |  |  |  |  |  |  |  |  |
| 14341075 |  | Proc 2 single-board PC's for DCs, Hodoscopes, Cerenkovs for DF2 | 49d | 2012-04-02 A | 2012-06-11 A | 9-120M FS+85d | 100% |  |  |  |  |  |  | PROCUREMENT<$50K 60 NO ESCALATION FY13 | 7,000 |  | 7000 |  |  | 0 | 7000 | 700000 | 100 | FENKER H | 1 | 1 | D | HOWARD F | 10-069 |  | 11-026 | 11-046 |  |  |  |  |  |  | 0 | 07-024 | 08-016 | 09-012 | 12-012 |  |  |  |  |  |  |  |  |  |  |  |  |  |
| 14341090 |  | Proc SD Module for DF2 | 138d | 2012-04-02 A | 2012-10-15 A | 9-120M FS+85d | 100% |  |  |  |  |  |  | PROCUREMENT<$50K 60 NO ESCALATION FY13 | 2,500 |  | 2500 |  |  | 0 | 2500 | 250000 | 100 | FENKER H | 1 | 1 | D | HOWARD F | 10-069 |  | 11-026 | 11-046 |  |  |  |  |  |  | 0 | 07-024 | 08-016 | 09-012 | 12-012 |  |  |  |  |  |  |  |  |  |  |  |  |  |
| 14341110 |  | Proc positive high-voltage modules | 89d | 2012-05-11 A | 2012-09-17 A | 9-120M FS+85d | 100% |  |  |  |  |  |  | PROCUREMENT<$50K 60 NO ESCALATION FY13 | 10,000 |  | 10000 |  |  | 0 | 10000 | 1000000 | 100 | FENKER H | 1 | 1 | D | HOWARD F | 10-069 |  | 11-026 | 11-046 |  |  |  |  |  |  | 0 | 07-024 | 08-016 | 09-012 | 12-012 |  |  |  |  |  |  |  |  |  |  |  |  |  |
| 14341060 |  | Proc Cables & Connectors (FAST Electrnc's) | 33d | 2012-08-01 A | 2012-09-17 A | 9-120M FS+210d | 100% |  |  |  |  |  |  | PROCUREMENT<$50K 60 NO ESCALATION FY13 | 5,324.09 |  | 5324.09 |  |  | 0 | 5324.09 | 532409 | 100 | FENKER H | 1 | 1 | D | HOWARD F | 10-069 |  | 11-026 | 11-046 |  |  |  |  |  |  | 0 | 07-024 | 08-016 | 09-012 |  |  |  |  |  |  |  |  |  |  |  |  |  |  |
| 14341100 |  | Proc SSP Module for DF2 | 142d | 2012-10-01 A | 2013-02-11 A | 9-130M | 100% |  | 2012-10-01 | 2013-04-30 |  |  |  | PROCUREMENT<$50K 60 | 6,707.35 |  | 0 |  |  | 0 | 6707.35 | 670735 | 100 | FENKER H | 1 | 1 | D | HOWARD F | 10-069 |  | 11-026 | 11-046 | 12-022 |  |  |  |  |  | 0 | 07-024 | 08-016 | 09-012 | 12-012 |  |  |  |  |  |  |  |  |  |  |  |  |  |
| 14341105 |  | Proc 11 TDC modules with CAEN 1190 specs for DC, Cerenkovs, Hodoscopes - for DF2 | 245d | 2012-10-01 A | 2013-02-11 A | 9-130M | 100% |  | 2012-10-01 | 2013-09-25 |  |  |  | PROCUREMENT<$50K 60; PROCUREMENT>$50K 69 | 108,000 |  | 0 |  |  | 0 | 108000 | 10800000 | 100 | FENKER H | 1 | 1 | D | HOWARD F | 10-069 |  | 11-026 | 11-046 | 12-022 | 13-006 |  |  |  |  | 0 | 07-024 | 08-016 | 09-012 | 12-012 |  |  |  |  | XX |  |  |  |  |  |  |  |  |
| 14341000 |  | DAQ Trigger Development | 220d | 2013-01-02 A | 2013-08-30 A | 9-130M, 14341067 FS-30d | 100% |  | 2013-03-20 | 2014-02-07 |  |  |  | SCIENTIST [453.82 h] | 33,469.72 | 33,065.33 | 33065.3252 |  |  |  |  |  |  | FENKER H | 1 | 1 | S | HOWARD F | 10-069 | 11-025 | 11-026 | 11-046 |  |  |  |  |  |  | 17486.4 |  |  |  | 12-012 |  | 14341000 |  |  |  | 100 | 0 | 100 | 100 | ST | 12-054 |  |  |
| 14341067 |  | Assemble and Test VME Crates (FAST Electrnc's) REF. HallD 1544025 | 32.5d | 2013-02-01 A | 2013-02-16 A | 14341065 | 100% |  | 2013-03-01 | 2013-04-16 |  |  |  | SCIENTIST [40 h] | 2,914.4 | 2,914.4 | 2824.4 |  |  |  |  |  |  | FENKER H | 1 | 1 | H | HOWARD F | 10-069 | 11-025 | 11-026 | 11-046 |  |  |  |  |  |  | 0 | 07-024 | 08-016 | 09-012 | 12-012 |  |  |  |  |  |  |  |  |  |  |  |  |  |
| 14341080 |  | Proc TS Module for DF2 | 103d | 2013-07-01 A | 2013-08-26 A | 9-130M FS+180d | 100% |  | 2013-08-01 | 2014-01-03 |  |  |  | PROCUREMENT<$50K 60 | 4,127.6 |  | 0 |  |  | 0 | 4127.6 | 412760 | 100 | FENKER H | 1 | 1 | D | HOWARD F | 10-069 |  | 11-026 | 11-046 | 12-022 |  |  |  |  |  | 2063.8 | 07-024 | 08-016 | 09-012 | 12-012 |  |  |  |  |  |  |  |  |  |  |  |  |  |
| 14341120 |  | Re-Baseline Actuals Adjustment | 1d | 2013-08-30 A | 2013-08-30 A |  | 100% |  | 2013-09-03 | 2013-09-03 |  |  |  | PROCUREMENT>$50K 69 NO ESCALATION | 91,554.55 |  | 91554.55 | ADJ |  | 0 | 91554.55 | 9155455 | 100 |  |  |  |  |  |  |  |  |  |  |  |  |  |  |  |  |  |  |  |  |  |  |  |  |  |  |  |  |  |  |  |  |  |
| 24341000 |  | DAQ Trigger Development FY13 | 104d | 2013-09-03 A | 2014-02-10 | 9-130M FS+228d | 30% | 61d | 2013-10-01 | 2014-03-10 | 317d | 39d | 8/5 M-F w/JLAB Holidays ReBaseline | SCIENTIST [46.15 h] | 3,469.56 | 1,413.94 | 1008.7467 |  | 24341000 |  |  |  |  | FENKER H | 1 | 1 | S | HOWARD F | 10-069 | 11-025 | 11-026 | 11-046 |  | 13-006F |  | 13-015 | PR |  |  |  |  |  | 12-012 |  |  |  |  |  |  |  |  |  | ST | 12-054 | PE |  |
| 24341000a |  | DAQ Trigger Development FY14 | 84d | 2013-09-03 A | 2014-02-10 | 24341000 FS-100d | 30% | 61d | 2013-10-01 | 2014-02-10 | 317d | 131d | 8/5 M-F w/JLAB Holidays ReBaseline | SCIENTIST [193.85 h] | 14,573.64 | 5,939.15 | 4372.0929 |  | 24341000 |  |  |  |  | FENKER H | 1 | 1 | S | HOWARD F | 10-069 | 11-025 | 11-026 | 11-046 |  | 13-006F |  | 13-015 | PR | 14-001 |  |  |  |  | 12-012 |  |  |  |  |  |  |  |  |  | ST | 12-054 | PE |  |
| 24341085 |  | Proc CTP Module for DF2 | 43d | 2013-09-03 A | 2013-12-05 | 9-130M FS+228d |  | 23d | 2013-09-03 | 2013-10-31 | 355d | 169d | 8/5 M-F w/JLAB Holidays ReBaseline | PROCUREMENT<$50K 60 NO ESCALATION FY14 | 5,180.91 |  | 0 |  | 24341085 | 5180.91 | 0 | 0 | 100 | FENKER H | 1 | 1 | D | HOWARD F | 10-069 |  | 11-026 | 11-046 | 12-022 | 13-006F | EV | 13-015 | PR |  |  | 07-024 | 08-016 | 09-012 | 12-012 |  |  |  |  |  |  |  |  |  |  |  |  | OB |

Notes:
- 14341000: Steps: Establish test stand with production VME crates and modules (done); Build Single crate readout (done); Build a RHEL6 machine funning CODA 2.6.x single crate readout of production DAZ modules (done); Build a summing trigger using the preshower assembly instrument and establish cosmics readout with scintillato trigger o (done); Implement and test energy summing trigger (done); Establish multi-crate readout using new VXS TS and TI units (done); Establish multi-crate readout with VXS, VME, and FASTBUS units that we will use in Phase 1 experiments (done); Extablish verified inventory of all needed DAQ hardware for complete trigger (done)
- 24341000: Steps: Establish multi-crate readout using new-VXS TS and TI units (done); Establish multi-crate readout with VXS, VME, and FASTBUS units that we will use in phase-I experiments; Establish verified inventory of all needed DAQ hardware for complete trigger.
- 24341000a: Steps: Establish multi-crate readout using new-VXS TS and TI units (done); Establish multi-crate readout with VXS, VME, and FASTBUS units that we will use in phase-I experiments; Establish verified inventory of all needed DAQ hardware for complete trigger.

| ID | WBS | Activity | Duration | Start | Finish | Predecessors | Complete | Planned start | Planned finish | Total float | Free float | Calendar | Resources | Cost | Actual cost | MONTHLY EV COST | RESP - Responsibility | STRT%COMP for CM EVM | FNSH%COMP for CM EVM | CR 07-024 | EVMS Reporting Codes | CAM RESPONSIBLE | Duplications | CR 09-012 | CR 09-022 | CR 10-069 | CR 11-026 | CR 12-012 | CR 12-036 | CR 08-016 | Remaining Material Cost Based on % Compl | Claimed Material Cost Based on % Complet | Initial Claimed Material Calc | Claimed Material Divider | Calculated Remaining Total Cost | CR 10-076 | ReBaseline Actuals Adjustment | Original Activity ID Rebaseline | CR 13-006 | BOE Procurement | CR 13-015 | Post Rebaseline | CR 14-001 | CR 11-046 | CR 12-022 | Specification | Activities with Steps | BOE Labor | BOE Expenses | CR 11-025 | CR 12-053 | CR 12-054 |
| --- | --- | --- | --- | --- | --- | --- | --- | --- | --- | --- | --- | --- | --- | --- | --- | --- | --- | --- | --- | --- | --- | --- | --- | --- | --- | --- | --- | --- | --- | --- | --- | --- | --- | --- | --- | --- | --- | --- | --- | --- | --- | --- | --- | --- | --- | --- | --- | --- | --- | --- | --- | --- |
|  | 2 | **1.4.3.4.2 POWER SUPPLIES & PROBES (Power Supply Infrastructure)** |  | 2011-04-02 | 2014-02-05 |  |  |  |  |  |  |  |  |  |  |  |  |  |  |  |  |  |  |  |  |  |  |  |  |  |  |  |  |  |  |  |  |  |  |  |  |  |  |  |  |  |  |  |  |  |  |  |
| 14342005 |  | Proc 4 Pwr Supplies for 480V (PWR SUP) | 11d | 2011-04-02 A | 2011-04-18 A | 9-110M FS+30d | 100% | 2011-04-04 | 2011-04-18 |  |  |  |  |  |  | 0 | FENKER H | 1 | 1 | 07-024 | Z | HOWARD F | DUP | 09-012 | 09-022 | 10-069 | 11-026 | 12-012 | 12-036F |  |  |  |  |  |  |  |  |  |  |  |  |  |  |  |  |  |  |  |  |  |  |  |
| 14342010 |  | Proc LCW Sys for Pwr Supplies (PWR SUP) | 6d | 2011-04-02 A | 2011-04-11 A | 14342005 | 100% | 2011-04-04 | 2011-04-11 |  |  |  |  |  |  | 0 | FENKER H | 1 | 1 | 07-024 | Z | HOWARD F | DUP | 09-012 | 09-022 | 10-069 | 11-026 | 12-012 | 12-036F |  |  |  |  |  |  |  |  |  |  |  |  |  |  |  |  |  |  |  |  |  |  |  |
| 14342030 |  | Proc 5000A Flexible Lines (PWR SUP) | 6d | 2011-04-02 A | 2011-04-11 A | 14342020, 9-120M FS+42d | 100% | 2011-04-04 | 2011-04-11 |  |  |  |  |  |  | 0 | FENKER H | 1 | 1 | 07-024 | Z | HOWARD F | DUP | 09-012 | 09-022 | 10-069 | 11-026 | 12-012 | 12-036F |  |  |  |  |  |  |  |  |  |  |  |  |  |  |  |  |  |  |  |  |  |  |  |
| 14342035 |  | Fab Stand for Pwr Supplies (PWR SUP) | 6d | 2011-04-02 A | 2011-04-11 A | 9-120M FS+42d, 14342005 | 100% | 2011-04-04 | 2011-04-11 |  |  |  |  |  |  | 0 | FENKER H | 1 | 1 | 07-024 | Z | HOWARD F | DUP |  | 09-022 | 10-069 | 11-026 | 12-012 | 12-036F |  |  |  |  |  |  |  |  |  |  |  |  |  |  |  |  |  |  |  |  |  |  |  |
| 14342020 |  | Proc 5000A Rigid Water Cooled Bus (PWR SUP) | 6d | 2011-04-03 A | 2011-04-11 A | 14342010 | 100% | 2011-04-04 | 2011-04-11 |  |  |  |  |  |  | 0 | FENKER H | 1 | 1 | 07-024 | Z | HOWARD F | DUP | 09-012 | 09-022 | 10-069 | 11-026 | 12-012 | 12-036F | 08-016 |  |  |  |  |  |  |  |  |  |  |  |  |  |  |  |  |  |  |  |  |  |  |
| 14342040 |  | Fab Catwalk (PWR SUP) | 5d | 2011-04-05 A | 2011-04-11 A | 14342035, 14342030 | 100% |  |  |  |  |  |  |  |  | 0 | FENKER H | 1 | 1 | 07-024 | Z | HOWARD F | DUP |  | 09-022 | 10-069 | 11-026 | 12-012 | 12-036F |  |  |  |  |  |  |  |  |  |  |  |  |  |  |  |  |  |  |  |  |  |  |  |
| 14342045 |  | Fab Cable Tray & Bus Supprt (PWR SUP) | 9d | 2011-04-06 A | 2011-04-18 A | 14342040 | 100% |  |  |  |  |  |  |  |  | 0 | FENKER H | 1 | 1 | 07-024 | Z | HOWARD F | DUP | 09-012 | 09-022 | 10-069 | 11-026 | 12-012 | 12-036F |  |  |  |  |  |  |  |  |  |  |  |  |  |  |  |  |  |  |  |  |  |  |  |
| 14342050 |  | Proc 5000A Flexible Lines Revised by 2012 ETC | 31d | 2012-10-01 A | 2012-11-12 A | 9-130M | 100% |  |  |  |  |  | PROCUREMENT>$50K 69; PROCUREMENT<$50K 60 | 61,914 |  | 61914 | FENKER H | 1 | 1 | 07-024 | D | HOWARD F | DUP | 09-012 | 09-022 | 10-069 | 11-026 | 12-012 | 12-036F |  | 0 | 61914 | 6191400 | 100 | 0 | 10-076 |  |  |  |  |  |  |  |  |  |  |  |  |  |  |  |  |
| 14342060 |  | Re-Baseline Actuals Adjustment | 1d | 2013-08-30 A | 2013-08-30 A |  | 100% | 2013-09-03 | 2013-09-03 |  |  |  | PROCUREMENT>$50K 69 NO ESCALATION | -28,650.28 |  |  |  |  |  |  |  |  |  |  |  |  |  |  |  |  |  |  |  | 100 |  |  | ADJ |  |  |  |  |  |  |  |  |  |  |  |  |  |  |  |
| 24342055 |  | Fab Cable Tray & Bus Support | 58d | 2013-11-01 | 2014-02-05 | 9-140M |  |  |  | 271d | 28d | 8/5 M-F w/JLAB Holidays ReBaseline | PROCUREMENT<$50K 60 | 26,620.44 |  | 0 | FENKER H | 1 | 1 | 07-024 | D | HOWARD F | DUP | 09-012 | 09-022 | 10-069 | 11-026 | 12-012 | 12-036F |  | 26620.44 | 0 | 0 | 100 |  | 10-076 |  | 24342055 | 13-006 | EJ | 13-015 | PR | 14-001 |  |  |  |  |  |  |  |  |  |
|  | 5 | **1.4.3.5 BEAMLINE** |  | 2011-04-04 | 2015-05-01 |  |  |  |  |  |  |  |  |  |  |  |  |  |  |  |  |  |  |  |  |  |  |  |  |  |  |  |  |  |  |  |  |  |  |  |  |  |  |  |  |  |  |  |  |  |  |  |
|  | 1 | **1.4.3.5.1 MOELLER POLARIMETER** |  | 2012-06-02 | 2014-04-14 |  |  |  |  |  |  |  |  |  |  |  |  |  |  |  |  |  |  |  |  |  |  |  |  |  |  |  |  |  |  |  |  |  |  |  |  |  |  |  |  |  |  |  |  |  |  |  |
| 14351005 |  | Proc Pwr Supply for Additional quad for Moeller polarimeter | 10d | 2012-06-02 A | 2012-06-18 A | 9-100M, 2-02M | 100% | 2012-06-05 | 2012-06-18 |  |  |  |  |  |  | 0 | FENKER H | 1 | 1 |  | Z | HOWARD F |  |  |  | 10-069 | 11-026 |  |  |  |  |  |  |  |  |  |  |  | 13-006F |  |  |  |  | 11-046 |  |  |  |  |  |  |  |  |
| 14351010 |  | Proc Cables/Stand for Additional quad for Moeller polarimeter | 40d | 2013-05-03 A | 2013-05-29 A | 2-02M, 9-130M FS+142d | 100% | 2013-06-03 | 2013-07-29 |  |  |  | PROCUREMENT<$50K 60 | 7,847.63 |  | 7847.63 | FENKER H | 1 | 1 |  | H | HOWARD F |  |  |  | 10-069 | 11-026 |  |  |  | 0 | 7847.63 | 784763 | 100 | 0 |  |  |  | 13-006F |  |  |  |  | 11-046 | 12-022 |  |  |  |  |  |  |  |
| 14351020 |  | Modify Moeller Collimator- Manufacturing Drawings | 18d | 2013-08-30 A | 2013-08-30 A | 9-140M FS+13d, 2-02M, 9-130M FS+235d | 100% | 2013-10-18 | 2013-11-12 |  |  |  | PROCUREMENT<$50K 60 NO ESCALATION FY14; MECH DES [160 h]; SCIENTIST | 8,208 | 7,953.6 | 7953.6 | FENKER H | 1 | 1 |  | S | HOWARD F |  |  |  | 10-069 | 11-026 |  |  |  |  |  |  |  | 7953.6 |  |  |  | 13-006 |  |  |  |  |  | 12-022 | 14351020 | ST |  |  |  |  |  |
| 14351025 |  | Re-Baseline Actuals Adjustment | 1d | 2013-08-30 A | 2013-08-30 A |  | 100% | 2013-09-03 | 2013-09-03 |  |  |  | PROCUREMENT>$50K 69 NO ESCALATION | -15,801.23 |  |  |  |  |  |  |  |  |  |  |  |  |  |  |  |  |  |  |  | 100 |  |  | ADJ |  |  |  |  |  |  |  |  |  |  |  |  |  |  |  |
| 24351020 |  | Modify Moeller Collimator- Manufacturing Drawings | 65d | 2013-11-01 | 2014-02-14 | 9-140M FS+13d |  |  |  | 458d | 0d | 8/5 M-F w/JLAB Holidays ReBaseline | MECH DES [160 h] | 8,208 |  | 0 | FENKER H | 1 | 1 |  | H | HOWARD F |  |  |  | 10-069 | 11-026 |  |  |  |  |  |  |  |  |  |  | 24351020 | 13-006 | EJ | 13-015 | PR | 14-001 |  | 12-022 |  |  | EJ |  |  |  |  |
| 24351030 |  | Modify Moeller Collimator - FAB/PROCURE | 41d | 2014-02-17 | 2014-04-14 | 24351020, 9-140M |  |  |  | 516d | 41d | 8/5 M-F w/JLAB Holidays ReBaseline | MECH DES [80 h]; MECH TECH [56 h]; MSHOP; PROCUREMENT<$50K 60 | 41,112.06 |  | 0 | FENKER H | 1 | 1 |  | D | HOWARD F |  |  |  |  |  |  |  |  | 24039.14 | 0 | 0 | 100 |  |  |  | 24351030 | 13-006 | EJ | 13-015 | PR | 14-001 |  |  |  |  | EJ | EJ |  |  |  |
|  | 2 | **1.4.3.5.2 COMPTON POLARIMETER** |  | 2011-04-04 | 2013-08-30 |  |  |  |  |  |  |  |  |  |  |  |  |  |  |  |  |  |  |  |  |  |  |  |  |  |  |  |  |  |  |  |  |  |  |  |  |  |  |  |  |  |  |  |  |  |  |  |
| 14352005 |  | Procure QR Magnets for Compton | 16d | 2011-04-04 A | 2011-04-25 A | 9-120M FS+70d | 100% |  |  |  |  |  |  |  |  | 0 | FENKER H | 1 | 1 |  | Z | HOWARD F |  |  |  | 10-069 | 11-026 |  |  |  |  |  |  |  |  |  |  |  |  |  |  |  |  | 11-046 |  |  |  |  |  |  |  |  |
| 14352000 |  | Produce Compton Elevation Layout FY12 | 164d | 2012-07-02 A | 2013-04-15 A | 9-120M FS+150d | 100% | 2012-07-02 | 2013-03-01 |  |  |  | MECH DES [310.4 h] | 15,243.44 | 15,272.38 | 14951.968 | FENKER H | 1 | 1 |  | H | HOWARD F |  |  |  | 10-069 | 11-026 | 12-012 |  |  |  |  |  |  | 0 |  |  |  |  |  |  |  |  | 11-046 |  | 14352000 |  |  |  | 11-025 | 12-053 | 12-054F |
| 14352000a |  | Produce Compton Elevation Layout FY13 | 164d | 2012-07-02 A | 2013-04-15 A | 14352000 FS-100d | 100% | 2012-07-02 | 2013-03-01 |  |  |  | MECH DES [9.6 h] | 471.45 | 472.36 | 477.216 | FENKER H | 1 | 1 |  | H | HOWARD F |  |  |  | 10-069 | 11-026 | 12-012 |  |  |  |  |  |  | 0 |  |  |  |  |  |  |  |  | 11-046 |  |  |  |  |  | 11-025 | 12-053 | 12-054F |
| 14352010 |  | Re-Baseline Actuals Adjustment | 1d | 2013-08-30 A | 2013-08-30 A |  | 100% | 2013-09-03 | 2013-09-03 |  |  |  | PROCUREMENT>$50K 69 NO ESCALATION | -6,416.3 |  |  |  |  |  |  |  |  |  |  |  |  |  |  |  |  |  |  |  | 100 |  |  | ADJ |  |  |  |  |  |  |  |  |  |  |  |  |  |  |  |

Notes:
- 14351020: Steps: Modify Moeller Collimator- Manufacturing Drawings (done)

| ID | WBS | Activity | Duration | Start | Finish | Predecessors | Complete | Remaining | Planned start | Planned finish | Total float | Free float | Calendar | Resources | Cost | Actual cost | Specification | Calculated Remaining Total Cost | MONTHLY EV COST | RESP - Responsibility | STRT%COMP for CM EVM | FNSH%COMP for CM EVM | EVMS Reporting Codes | CAM RESPONSIBLE | CR 09-022 | CR 10-025 | CR 10-069 | CR 11-026 | CR 11-046 | CR 12-012 | CR 12-022 | CR 13-006 | Remaining Material Cost Based on % Compl | Claimed Material Cost Based on % Complet | Initial Claimed Material Calc | Claimed Material Divider | CR 08-016 | CR 09-012 | ReBaseline Actuals Adjustment | Original Activity ID Rebaseline | PRIOR MONTH EV COST | BOE Procurement | BOE Labor | CR 13-015 | Post Rebaseline | CR 14-001 | BOE Expenses | MARCH!!! | CR 12-001 | Activities with Steps |
| --- | --- | --- | --- | --- | --- | --- | --- | --- | --- | --- | --- | --- | --- | --- | --- | --- | --- | --- | --- | --- | --- | --- | --- | --- | --- | --- | --- | --- | --- | --- | --- | --- | --- | --- | --- | --- | --- | --- | --- | --- | --- | --- | --- | --- | --- | --- | --- | --- | --- | --- |
|  | 3 | **1.4.3.5.3 MAPPING** |  | 2013-08-30 | 2014-04-28 |  |  |  |  |  |  |  |  |  |  |  |  |  |  |  |  |  |  |  |  |  |  |  |  |  |  |  |  |  |  |  |  |  |  |  |  |  |  |  |  |  |  |  |  |  |
| 14353010 |  | Fabricate and Use New ARC Mapper | 77d | 2013-08-30 A | 2013-08-30 A | 9-130M FS+228d | 100% |  | 2013-09-03 | 2013-12-20 |  |  |  | ELEC TECH; MECH DES; MECH TECH [320 h]; MECH ENG; SCIENTIST [288 h]; PROCUREMENT<$50K 60 | 36,499.34 | 35,658.88 | 14353010 | 52265.09 | 35658.88 | FENKER H | 1 | 1 | U | HOWARD F | 09-022 | 10-025 | 10-069 | 11-026 | 11-046 | 12-012 | 12-022 | 13-006 |  |  |  |  |  |  |  |  |  |  |  |  |  |  |  |  |  |  |
| 14353015 |  | Refurb Existing Harmonic Coil for SHMS Mags | 100d | 2013-08-30 A | 2013-08-30 A | 9-130M FS+120d, 9-140M | 100% |  | 2013-10-01 | 2014-03-03 |  |  |  | SUPPLIES & MATERIALS; MSHOP; MECH DES [200 h]; ELEC TECH [200 h]; SCIENTIST [160 h]; TRAVEL; MECH ENG [200 h]; PROCUREMENT<$50K 60 | 123,370.72 | 45,179.6 | 14353015 | 121929.52 | 121929.52 | FENKER H | 1 | 1 | U | HOWARD F | 09-022 |  | 10-069 | 11-026 | 11-046 | 12-012 |  | 13-006 | 0 | 44731.54 | 4473154 | 100 | 08-016 | 09-012 |  |  |  |  |  |  |  |  |  |  |  |  |
| 14353020 |  | Re-Baseline Actuals Adjustment | 1d | 2013-08-30 A | 2013-08-30 A |  | 100% |  | 2013-09-03 | 2013-09-03 |  |  |  | PROCUREMENT>$50K 69 NO ESCALATION | -157,588.4 |  |  |  |  |  |  |  |  |  |  |  |  |  |  |  |  |  |  |  |  | 100 |  |  | ADJ |  |  |  |  |  |  |  |  |  |  |  |
| 24353010 |  | Fabricate and Use New ARC Mapper FY13 | 77d | 2013-09-03 A | 2013-12-20 | 9-130M FS+228d | 41% | 34d | 2013-10-01 | 2014-01-30 | 494d | 26d | 8/5 M-F w/JLAB Holidays ReBaseline | SCIENTIST [93.51 h]; MECH TECH [103.89 h] | 11,946.15 | 6,575.48 |  |  | 0 | FENKER H | 1 | 1 | U | HOWARD F | 09-022 | 10-025 | 10-069 | 11-026 | 11-046 | 12-012 | 12-022 | 13-006F |  |  |  |  |  |  |  | 24353010 | 4746.73650141 | EJ | EJ | 13-015 | PR |  |  |  |  |  |
| 24353010a |  | Fabricate and Use New ARC Mapper FY14 | 57d | 2013-09-03 A | 2013-12-20 | 24353010 FS-60d | 41% | 34d | 2013-10-01 | 2013-12-20 | 494d |  | 8/5 M-F w/JLAB Holidays ReBaseline | SCIENTIST [266.49 h]; MECH TECH [296.11 h] | 34,046.77 | 18,740.26 |  |  | 0 | FENKER H | 1 | 1 | U | HOWARD F | 09-022 | 10-025 | 10-069 | 11-026 | 11-046 | 12-012 | 12-022 | 13-006F |  |  |  |  |  |  |  | 24353010 | 13959.17790293 | EJ | EJ | 13-015 | PR | 14-001 |  |  |  |  |
| 24353015 |  | Refurb Existing Harmonic Coil for SHMS Mags | 75d | 2014-01-13 | 2014-04-28 | 9-140M FS+66d |  |  |  |  | 372d | 102d | 8/5 M-F w/JLAB Holidays ReBaseline | MECH TECH [16 h]; PROCUREMENT<$50K 60; MECH DES [200 h]; ELEC TECH [200 h]; SCIENTIST [160 h]; TRAVEL; MECH ENG [200 h]; SUPPLIES & MATERIALS; MSHOP | 126,576.16 |  |  |  | 0 | FENKER H | 1 | 1 | U | HOWARD F | 09-022 |  | 10-069 | 11-026 | 11-046 | 12-012 |  | 13-006 | 46158.48 | 0 | 0 | 100 | 08-016 | 09-012 |  | 24353015 |  | EJ | EJ | 13-015 | PR | 14-001 | EJ |  |  |  |
|  | 4 | **1.4.3.5.4 SCATTERING CHAMBER** |  | 2011-08-01 | 2014-09-04 |  |  |  |  |  |  |  |  |  |  |  |  |  |  |  |  |  |  |  |  |  |  |  |  |  |  |  |  |  |  |  |  |  |  |  |  |  |  |  |  |  |  |  |  |  |
| 14354005 |  | Modify Existing Chamb Cylinder (SCATTER CHAMB) | 23d | 2011-08-01 A | 2011-08-31 A | 9-110M FS+60d | 100% |  |  |  |  |  |  | PROCUREMENT<$50K 60; MECH ENG [40 h]; MECH TECH [80 h]; TRAVEL | 43,310.8 | 6,163.6 |  | 0 | 43310.8 | FENKER H | 1 | 1 | H | HOWARD F | 09-022 |  | 10-069 | 11-026 | 11-046 | 12-012 | 12-022F | 13-006F | 0 | 33632.31 | 3363231 | 100 | 08-016 | 09-012 |  |  |  |  |  |  |  |  |  |  |  |  |
| 14354025 |  | Proc Turbo Pump Sys (SCATTER CHAMB) | 79d | 2012-10-01 A | 2013-03-11 A | 14354005 | 100% |  | 2012-10-01 | 2013-01-30 |  |  |  | PROCUREMENT<$50K 60 | 44,671.18 |  |  | 0 | 44671.18 | FENKER H | 1 | 1 | D | HOWARD F | 09-022 |  | 10-069 | 11-026 | 11-046 | 12-012 | 12-022 | 13-006F | 0 | 44671.18 | 4467118 | 100 |  |  |  |  |  |  |  |  |  |  |  | XX |  |  |
| 14354008 |  | Proc & Fab Chamb Flanges (SCATTER CHAMB) | 80d | 2013-08-30 A | 2013-08-30 A | 9-140M FS+100d, 9-130M FS+130d | 100% |  | 2014-03-04 | 2014-06-24 |  |  |  | MSHOP | 10,000 |  |  | 10000 | 10000 | FENKER H | 1 | 1 | H | HOWARD F |  |  |  |  |  |  |  | 13-006 |  |  |  |  |  |  |  |  |  |  |  |  |  |  |  |  |  |  |
| 14354010 |  | Proc & Install Chamb Flanges (SCATTER CHAMB) | 130d | 2013-08-30 A | 2013-08-30 A | 9-120M FS+210d, 9-110M, 14354008 FS-600d, 14354005, 9-130M FS+130d, 9-140M FS+100d | 100% |  | 2014-03-04 | 2014-09-04 |  |  |  | MECH TECH [40 h]; MECH ENG [40 h] | 4,879.6 | 4,728.8 | 14354010 | 4440.8 | 4440.8 | FENKER H | 1 | 1 | H | HOWARD F | 09-022 |  | 10-069 | 11-026 | 11-046 | 12-012 | 12-022F | 13-006F |  |  |  |  |  |  |  |  |  |  |  |  |  |  |  |  |  |  |
| 14354015 |  | Proc & Install HMS & SHMS Window Frames (SCATTER CHAMB) FY11 | 130d | 2013-08-30 A | 2013-08-30 A | 14354010 FS-130d | 100% |  | 2014-03-04 | 2014-09-04 |  |  |  | MECH DES [43 h]; MECH ENG [21.5 h]; MECH TECH [86 h] | 7,880.83 | 7,637.23 | 14354015 | 7172.185 | 7172.185 | FENKER H | 1 | 1 | H | HOWARD F | 09-022 |  | 10-069 | 11-026 | 11-046 | 12-012 | 12-022F | 13-006F |  |  |  |  |  |  |  |  |  |  |  |  |  |  |  |  | 12-001 |  |
| 14354015a |  | Proc & Install HMS & SHMS Window Frames (SCATTER CHAMB) FY12 | 130d | 2013-08-30 A | 2013-08-30 A | 14354015 FS-130d | 100% |  | 2014-03-04 | 2014-09-04 |  |  |  | MECH TECH [74 h]; MECH DES [37 h]; MECH ENG [18.5 h] | 6,781.18 | 6,571.57 | 14354015a | 6368.07 | 6368.07 | FENKER H | 1 | 1 | H | HOWARD F | 09-022 |  | 10-069 | 11-026 | 11-046 | 12-012 | 12-022F | 13-006F |  |  |  |  |  |  |  |  |  |  |  |  |  |  |  |  | 12-001 |  |
| 14354020 |  | Proc & Install HMS & SHMS Blank Covers (SCATTER CHAMB) | 130d | 2013-08-30 A | 2013-08-30 A | 14354015a FS-130d | 100% |  | 2014-03-04 | 2014-09-04 |  |  |  | MECH DES [160 h] | 8,208 | 7,953.6 | 14354020 | 7707.2 | 7707.2 | FENKER H | 1 | 1 | H | HOWARD F | 09-022 |  | 10-069 | 11-026 | 11-046 | 12-012 | 12-022F | 13-006F |  |  |  |  |  |  |  |  |  |  |  |  |  |  |  |  |  |  |
| 14354030 |  | Proc & Install Gate Valves,BL adaptors & Vac Gauges (SCATTER CHAMB) Original Labor | 130d | 2013-08-30 A | 2013-08-30 A | 14354020 FS-180d, 9-140M FS+100d, 9-130M FS+130d | 100% |  | 2014-03-04 | 2014-09-04 |  |  |  | TRAVEL; MECH ENG [22.4 h]; MECH TECH [33.6 h]; MECH DES [89.6 h]; PLABOR; SUPPLIES & MATERIALS | 17,225.17 | 7,615.78 | 14354030 | 16746.034 | 16746.034 | FENKER H | 1 | 1 | U | HOWARD F | 09-022 |  | 10-069 | 11-026 | 11-046 | 12-012 | 12-022 | 13-006F |  |  |  |  | 08-016 | 09-012 |  |  |  |  |  |  |  |  |  |  |  |  |
| 14354035 |  | Re-Baseline Actuals Adjustment | 1d | 2013-08-30 A | 2013-08-30 A |  | 100% |  | 2013-09-03 | 2013-09-03 |  |  |  | PROCUREMENT>$50K 69 NO ESCALATION | -107,037.97 |  |  |  |  |  |  |  |  |  |  |  |  |  |  |  |  |  |  |  |  | 100 |  |  | ADJ |  |  |  |  |  |  |  |  |  |  |  |
| 24354008 |  | Proc & Fab Chamb Flanges (SCATTER CHAMB) | 80d | 2014-03-04 | 2014-06-24 | 9-140M FS+100d |  |  |  |  | 810d | 520d | 8/5 M-F w/JLAB Holidays ReBaseline | MSHOP | 10,319 |  |  |  | 0 | FENKER H | 1 | 1 | U | HOWARD F |  |  |  |  |  |  |  | 13-006 |  |  |  |  |  |  |  | 24354008 |  |  |  | 13-015 | PR | 14-001 | PE |  |  |  |
| 24354010 |  | Procure and Install Chamb Flanges (SCATTER CHAMB) | 130d | 2014-03-04 | 2014-09-04 | 9-140M FS+100d, 24354008 FS-600d |  |  |  |  | 342d | 0d | 8/5 M-F w/JLAB Holidays ReBaseline | MECH ENG [40 h]; MECH TECH [40 h] | 4,879.6 |  |  |  | 0 | FENKER H | 1 | 1 | U | HOWARD F | 09-022 |  | 10-069 | 11-026 | 11-046 | 12-012 | 12-022 |  |  |  |  |  |  |  |  | 24354010 |  |  | PE | 13-015 | PR | 14-001 |  |  |  |  |
| 24354015a |  | Proc & Install HMS & SHMS Window Frames (SCATTER CHAMB) | 130d | 2014-03-04 | 2014-09-04 | 24354010 FS-130d, 9-140M FS+100d |  |  |  |  | 342d | 0d | 8/5 M-F w/JLAB Holidays ReBaseline | MECH TECH [160 h]; MECH DES [80 h]; MECH ENG [40 h] | 14,662 |  |  |  | 0 | FENKER H | 1 | 1 | U | HOWARD F | 09-022 |  | 10-069 | 11-026 | 11-046 | 12-012 | 12-022 |  |  |  |  |  |  |  |  | 24354015a |  |  | PE | 13-015 | PR | 14-001 |  |  | 12-001 |  |
| 24354020 |  | Proc & Install HMS & SHMS Blank Covers (SCATTER CHAMB) | 130d | 2014-03-04 | 2014-09-04 | 24354015a FS-130d, 9-140M FS+100d |  |  |  |  | 342d | 0d | 8/5 M-F w/JLAB Holidays ReBaseline | MECH DES [160 h] | 8,208 |  |  |  | 0 | FENKER H | 1 | 1 | U | HOWARD F | 09-022 |  | 10-069 | 11-026 | 11-046 | 12-012 | 12-022 |  |  |  |  |  |  |  |  | 24354020 |  |  | PE | 13-015 | PR | 14-001 |  |  |  |  |
| 24354022 |  | Modify Seal on Scattering Chamber | 120d | 2014-03-04 | 2014-08-20 | 9-140M FS+100d |  |  |  |  | 322d | 89d | 8/5 M-F w/JLAB Holidays ReBaseline | MECH DES [400 h]; MECH ENG [400 h]; PROCUREMENT<$50K 60 | 60,707 |  |  |  | 0 | FENKER H | 1 | 1 | S | HOWARD F |  |  |  |  |  |  |  | 13-006 | 10319 | 0 | 0 | 100 |  |  |  | 24354022 |  | PE | PE | 13-015 | PR | 14-001 |  |  |  | ST |
| 24354030 |  | Proc & Install Gate Valves,BL adaptors & Vac Gauges (SCATTER CHAMB) Labor | 75d | 2014-03-04 | 2014-06-17 | 24354020 FS-130d, 9-140M FS+100d |  |  |  |  | 342d |  | 8/5 M-F w/JLAB Holidays ReBaseline | MECH ENG [80 h]; MECH TECH [120 h]; MECH DES [320 h]; SUPPLIES & MATERIALS; PLABOR; TRAVEL | 46,990.03 |  |  |  | 0 | FENKER H | 1 | 1 | U | HOWARD F | 09-022 |  | 10-069 | 11-026 | 11-046 | 12-012 | 12-022 | 13-006F |  |  |  |  | 08-016 | 09-012 |  | 24354030 |  | EJ | EJ | 13-015 | PR | 14-001 | EJ |  |  |  |
| 24354030b |  | Proc & Install Gate Valves,BL adaptors & Vac Gauges (SCATTER CHAMB) Procurement | 75d | 2014-03-04 | 2014-06-17 | 9-140M FS+100d |  |  |  |  | 342d | 134d | 8/5 M-F w/JLAB Holidays ReBaseline | PROCUREMENT<$50K 60 | 37,375.29 |  |  |  | 0 | FENKER H | 1 | 1 | D | HOWARD F | 09-022 |  | 10-069 | 11-026 | 11-046 | 12-012 | 12-022 |  | 37375.29 | 0 | 0 | 100 | 08-016 | 09-012 |  | 24354030b |  | EJ |  | 13-015 | PR | 14-001 |  |  |  |  |

Notes:
- 24354022: Steps: Inspect/Check seal; Spec modified seal; Design modified seal; Fabricate modified seal; Install modified seal; Test/Certify modified seal

| ID | WBS | Activity | Type | Duration | Start | Finish | Predecessors | Complete | Planned start | Planned finish | Total float | Free float | Calendar | Resources | Cost | Actual cost | Specification | Calculated Remaining Total Cost | MONTHLY EV COST | RESP - Responsibility | STRT%COMP for CM EVM | FNSH%COMP for CM EVM | EVMS Reporting Codes | CAM RESPONSIBLE | CR 10-069 | CR 11-026 | CR 11-046 | CR 12-012 | CR 12-054 | CR 13-006 | Claimed Material Divider | ReBaseline Actuals Adjustment | Original Activity ID Rebaseline | Activities with Steps | BOE Labor | CR 13-015 | Post Rebaseline | CR 14-001 | Remaining Material Cost Based on % Compl | Claimed Material Cost Based on % Complet | Initial Claimed Material Calc | BOE Procurement | BOE Expenses | CR 08-016 | CR 09-012 | Advance Purchase Plan > 500K | CR 08-052 | 12 GEV MAJOR PROCUREMENT CATAGORY | CR 09-022 | CR 11-025 | CR 12-036 | Milestone Level | CR 12-001 | LOE % Pre Calc | LOE % | LOE Divider | LOE Multiplier | MARCH!!! | BOE NOTES | PRIOR MONTH EV COST | CR 10-025 | CR 12-055 | Obligated Prior to Rebaseline |
| --- | --- | --- | --- | --- | --- | --- | --- | --- | --- | --- | --- | --- | --- | --- | --- | --- | --- | --- | --- | --- | --- | --- | --- | --- | --- | --- | --- | --- | --- | --- | --- | --- | --- | --- | --- | --- | --- | --- | --- | --- | --- | --- | --- | --- | --- | --- | --- | --- | --- | --- | --- | --- | --- | --- | --- | --- | --- | --- | --- | --- | --- | --- | --- |
|  | 5 | **1.4.3.5.5 BEAM PIPE & STANDS** |  |  | 2013-08-30 | 2015-05-01 |  |  |  |  |  |  |  |  |  |  |  |  |  |  |  |  |  |  |  |  |  |  |  |  |  |  |  |  |  |  |  |  |  |  |  |  |  |  |  |  |  |  |  |  |  |  |  |  |  |  |  |  |  |  |  |  |  |
| 14355010 |  | Proc 2nd Section of Beam Pipe (Beam Pipe) |  | 130d | 2013-08-30 A | 2013-08-30 A | 9-130M FS+225d | 100% | 2013-09-03 | 2014-03-17 |  |  |  | MECH DES [5.54 h]; MECH ENG [1.85 h]; MECH TECH [1.85 h]; PROCUREMENT<$50K 60 NO ESCALATION FY14 | 506.86 | 493.53 | 14355010 | 42564.55 | 493.5281 | FENKER H | 1 | 1 | H | HOWARD F | 10-069 | 11-026 | 11-046 | 12-012 | 12-054 | 13-006F |  |  |  |  |  |  |  |  |  |  |  |  |  |  |  |  |  |  |  |  |  |  |  |  |  |  |  |  |  |  |  |  |  |
| 14355015 |  | Proc 3rd Section of Beam Pipe (Beam Pipe) |  | 130d | 2013-08-30 A | 2013-08-30 A | 9-130M FS+225d | 100% | 2013-09-03 | 2014-03-17 |  |  |  | PROCUREMENT>$50K 69; PROCUREMENT<$50K 60; MECH ENG [1.85 h]; MECH TECH [1.85 h]; MECH DES [6.46 h]; TRAVEL; PROCUREMENT<$50K 60 NO ESCALATION FY14; PROCUREMENT>$50K 69 NO ESCALATION FY14 | 611.21 | 539.25 | 14355015 | 52014.24 | 596.641104 | FENKER H | 1 | 1 | H | HOWARD F | 10-069 | 11-026 | 11-046 | 12-012 | 12-054 | 13-006F |  |  |  |  |  |  |  |  |  |  |  |  |  |  |  |  |  |  |  |  |  |  |  |  |  |  |  |  |  |  |  |  |  |
| 14355035 |  | Re-Baseline Actuals Adjustment |  | 1d | 2013-08-30 A | 2013-08-30 A |  | 100% | 2013-09-03 | 2013-09-03 |  |  |  | PROCUREMENT>$50K 69 NO ESCALATION | -1,090.17 |  |  |  |  |  |  |  |  |  |  |  |  |  |  |  | 100 | ADJ |  |  |  |  |  |  |  |  |  |  |  |  |  |  |  |  |  |  |  |  |  |  |  |  |  |  |  |  |  |  |  |
| 24355000 |  | Produce Manufacturing Drawings for Beam Pipe, Stands, Fittings |  | 65d | 2014-06-30 | 2014-09-30 | 9-140M FS+183d |  |  |  | 271d | 75d | 8/5 M-F w/JLAB Holidays ReBaseline | MECH DES [800 h]; MECH ENG [200 h] | 55,974 |  |  |  | 0 | FENKER H | 1 | 1 | S | HOWARD F |  |  |  |  |  | 13-006 |  |  | 24355000 | ST | PE | 13-015 | PR | 14-001 |  |  |  |  |  |  |  |  |  |  |  |  |  |  |  |  |  |  |  |  |  |  |  |  |  |
| 24355005 |  | Proc 1st Pipe (Beam Pipe) |  | 58d | 2014-10-01 | 2014-12-23 | 9-155M, 24355000 FS-75d |  |  |  | 196d | 84d | 8/5 M-F w/JLAB Holidays ReBaseline | MECH TECH [80 h]; MECH DES [160 h]; MECH ENG [80 h]; PROCUREMENT<$50K 60 | 32,119.97 |  |  |  | 0 | FENKER H | 1 | 1 | D | HOWARD F | 10-069 | 11-026 | 11-046 | 12-012 | 12-054 |  | 100 |  | 24355005 |  | EJ | 13-015 | PR | 14-001 | 14152.77 | 0 | 0 | EJ |  |  |  |  |  |  |  |  |  |  |  |  |  |  |  |  |  |  |  |  |  |
| 24355010 |  | Proc 2nd Section of Beam Pipe (Beam Pipe) |  | 55d | 2014-11-03 | 2015-02-02 | 9-155M FS+23d |  |  |  | 112d | 0d | 8/5 M-F w/JLAB Holidays ReBaseline | MECH DES [240 h]; MECH ENG [80 h]; MECH TECH [80 h]; PROCUREMENT<$50K 60 | 43,923.28 |  |  |  | 0 | FENKER H | 1 | 1 | D | HOWARD F | 10-069 | 11-026 | 11-046 | 12-012 | 12-054 |  | 100 |  | 24355010 |  | EJ | 13-015 | PR | 14-001 | 21852.08 | 0 | 0 | EJ |  |  |  |  |  |  |  |  |  |  |  |  |  |  |  |  |  |  |  |  |  |
| 24355015 |  | Proc 3rd Section of Beam Pipe (Beam Pipe) |  | 56d | 2014-12-02 | 2015-03-02 | 9-155M FS+42d |  |  |  | 112d | 0d | 8/5 M-F w/JLAB Holidays ReBaseline | MECH ENG [80 h]; MECH TECH [80 h]; MECH DES [280 h]; TRAVEL; PROCUREMENT<$50K 60; PROCUREMENT>$50K 69 | 53,674.59 |  |  |  | 0 | FENKER H | 1 | 1 | D | HOWARD F | 10-069 | 11-026 | 11-046 | 12-012 | 12-054 |  | 100 |  | 24355015 |  | EJ | 13-015 | PR | 14-001 | 26984.95 | 0 | 0 | EJ | EJ |  |  |  |  |  |  |  |  |  |  |  |  |  |  |  |  |  |  |  |  |
| 24355020 |  | Proc Windows & Window Spool (Beam Pipe) |  | 84d | 2015-01-05 | 2015-05-01 | 24355005 FS-90d, 24355010 FS-20d, 24355015 FS-40d |  |  |  | 117d | 5d | 8/5 M-F w/JLAB Holidays ReBaseline | MECH ENG [240 h]; MECH TECH [120 h]; MECH DES [240 h]; PROCUREMENT>$50K 69 | 71,916.07 |  |  |  | 0 | FENKER H | 1 | 1 | D | HOWARD F | 10-069 | 11-026 | 11-046 | 12-012 | 12-054 |  | 100 |  | 24355020 |  | EJ | 13-015 | PR | 14-001 | 36004.87 | 0 | 0 | EJ |  | 08-016 | 09-012 |  |  |  |  |  |  |  |  |  |  |  |  |  |  |  |  |  |  |
| 24355025 |  | Proc Beam Stands (Beam Pipe) |  | 84d | 2015-01-05 | 2015-05-01 | 24355015 FS-40d, 24355010 FS-20d, 24355005 FS-90d |  |  |  | 112d | 0d | 8/5 M-F w/JLAB Holidays ReBaseline | PROCUREMENT<$50K 60 | 18,002.42 |  |  |  | 0 | FENKER H | 1 | 1 | D | HOWARD F | 10-069 | 11-026 | 11-046 | 12-012 | 12-054 |  | 100 |  | 24355025 |  | EJ | 13-015 | PR | 14-001 | 18002.42 | 0 | 0 | EJ |  | 08-016 | 09-012 |  |  |  |  |  |  |  |  |  |  |  |  |  |  |  |  |  |  |
| 24355030 |  | Proc Vac Fittings (Beam Pipe) |  | 84d | 2015-01-05 | 2015-05-01 | 24355025 FS-84d |  |  |  | 122d | 10d | 8/5 M-F w/JLAB Holidays ReBaseline | PROCUREMENT<$50K 60 | 15,037.32 |  |  |  | 0 | FENKER H | 1 | 1 | D | HOWARD F | 10-069 | 11-026 | 11-046 | 12-012 | 12-054 |  | 100 |  | 24355030 |  | EJ | 13-015 | PR | 14-001 | 15037.32 | 0 | 0 | EJ |  |  |  |  |  |  |  |  |  |  |  |  |  |  |  |  |  |  |  |  |  |
|  | 6 | **1.4.3.5.6 MAGNET POWER SUPPLY** |  |  |  |  |  |  |  |  |  |  |  |  |  |  |  |  |  |  |  |  |  |  |  |  |  |  |  |  |  |  |  |  |  |  |  |  |  |  |  |  |  |  |  |  |  |  |  |  |  |  |  |  |  |  |  |  |  |  |  |  |  |
|  | 6 | **1.4.3.6 INFRASTUCTURE** |  |  | 2009-07-01 | 2015-12-23 |  |  |  |  |  |  |  |  |  |  |  |  |  |  |  |  |  |  |  |  |  |  |  |  |  |  |  |  |  |  |  |  |  |  |  |  |  |  |  |  |  |  |  |  |  |  |  |  |  |  |  |  |  |  |  |  |  |
|  | 1 | **1.4.3.6.1 ENGINEERING & DESIGN** |  |  |  |  |  |  |  |  |  |  |  |  |  |  |  |  |  |  |  |  |  |  |  |  |  |  |  |  |  |  |  |  |  |  |  |  |  |  |  |  |  |  |  |  |  |  |  |  |  |  |  |  |  |  |  |  |  |  |  |  |  |
|  | 2 | **1.4.3.6.2 SUPPORT STRUCTURE** |  |  | 2010-02-01 | 2013-09-16 |  |  |  |  |  |  |  |  |  |  |  |  |  |  |  |  |  |  |  |  |  |  |  |  |  |  |  |  |  |  |  |  |  |  |  |  |  |  |  |  |  |  |  |  |  |  |  |  |  |  |  |  |  |  |  |  |  |
| 14362005 |  | Finalize Dsgn of Supprt Struct |  | 169.5d | 2010-02-01 A | 2010-09-30 A | 14362000M | 100% |  |  |  |  |  | MECH DES [184.5 h]; PROCUREMENT<$50K 60; PROCUREMENT>$50K 69; MECH ENG [184.5 h] | 71,192.75 | 20,496.11 |  | 0 | 71192.745 | FENKER H | 1 | 1 | S | HOWARD F | 10-069 | 11-026 | 11-046 | 12-012 |  |  | 100 |  |  | ST |  |  |  |  | 0 | 50696.64 | 5069664 |  |  | 08-016 | 09-012 | APP | 08-052 | 4362B | 09-022 | 11-025 | 12-036F |  |  |  |  |  |  |  |  |  |  |  |  |
| 14362012 |  | Produce Drawings - Rails & Base of Supprt Struct |  | 53d | 2010-04-01 A | 2010-06-15 A | 14362046a FS-225d | 100% |  |  |  |  |  | MECH DES [320 h]; MECH ENG [160 h] | 25,012.8 | 25,012.8 |  | 0 | 25809.6 | FENKER H | 1 | 1 | H | HOWARD F | 10-069 | 11-026 | 11-046 | 12-012 |  | 13-006F |  |  |  |  |  |  |  |  |  |  |  |  |  |  |  | APP | 08-052 |  | 09-022 | 11-025 | 12-036F |  |  |  |  |  |  |  |  |  |  |  |  |
| 14362046 |  | Produce Drawings - Bogies |  | 74d | 2010-04-01 A | 2010-07-15 A | 14362046a FS-150d | 100% |  |  |  |  |  | MECH DES [400 h]; MECH ENG [200 h] | 31,266 | 31,266 |  | 0 | 32262 | FENKER H | 1 | 1 | H | HOWARD F | 10-069 | 11-026 | 11-046 | 12-012 | 12-054F | 13-006F |  |  |  |  |  |  |  |  |  |  |  |  |  | 08-016 |  | APP | 08-052 | 4362C | 09-022 | 11-025 | 12-036F |  |  |  |  |  |  |  |  |  |  |  |  |
| 14362046a |  | Produce Drawings - Wheels |  | 74d | 2010-04-01 A | 2010-07-15 A | 14362010M FS-150d | 100% |  |  |  |  |  | MECH DES [400 h]; MECH ENG [200 h] | 31,266 | 31,266 |  | 0 | 32262 | FENKER H | 1 | 1 | H | HOWARD F | 10-069 | 11-026 | 11-046 | 12-012 |  | 13-006F |  |  |  |  |  |  |  |  |  |  |  |  |  | 08-016 |  | APP | 08-052 | 4362C | 09-022 | 11-025 | 12-036F |  |  |  |  |  |  |  |  |  |  |  |  |
| 14362000M |  | Award Contract to Dsgn the Supprt Struct | milestone | 0d | 2010-04-26 A | 2010-04-26 A | 9-100M FS+142d, 12236830LOE, 12236040 | 100% | 2010-05-03 | 2010-05-03 |  |  |  |  |  |  |  |  | 0 | FENKER H | 1 | 1 | M | HOWARD F | 10-069 | 11-026 | 11-046 | 12-012 |  |  |  |  |  |  |  |  |  |  |  |  |  |  |  |  |  |  | 08-052 |  |  | 11-025 | 12-036F | 6 |  |  |  |  |  |  |  |  |  |  |  |
| 14362075 |  | Fab Main Bearing of Supprt Struct Labor FY11 |  | 245d | 2010-04-29 A | 2011-04-25 A | 14362005 FS-40d | 100% |  |  |  |  |  | MECH ENG [79.36 h]; MECH DES [79.36 h] | 8,973.2 | 8,973.2 |  | 0 | 9097.0368 | FENKER H | 1 | 1 | D | HOWARD F | 10-069 | 11-026 | 11-046 | 12-012 |  | 13-006F |  |  |  |  |  |  |  |  |  |  |  |  |  | 08-016 | 09-012 | APP | 08-052 |  | 09-022 | 11-025 | 12-036F |  | 12-001 |  |  |  |  |  |  |  |  |  |  |
| 14362075a |  | Fab Main Bearing of Supprt Struct Labor FY12 |  | 245d | 2010-04-29 A | 2011-04-25 A | 14362075 | 100% |  |  |  |  |  | MECH ENG [0.64 h]; MECH DES [0.64 h] | 72.37 | 72.37 |  | 0 | 75.7056 | FENKER H | 1 | 1 | D | HOWARD F | 10-069 | 11-026 | 11-046 | 12-012 |  | 13-006F |  |  |  |  |  |  |  |  |  |  |  |  |  | 08-016 | 09-012 | APP | 08-052 |  | 09-022 | 11-025 | 12-036F |  | 12-001 |  |  |  |  |  |  |  |  |  |  |
| 14362075b |  | Fab Main Bearing of Supprt Struct Procurement |  | 245d | 2010-04-29 A | 2011-04-25 A | 14362005 FS-40d | 100% |  |  |  |  |  | PROCUREMENT<$50K 60 NO ESCALATION FY12; PROCUREMENT>$50K 69 NO ESCALATION FY12 | 83,903.9 |  |  | 0 | 83903.9 | FENKER H | 1 | 1 | D | HOWARD F | 10-069 | 11-026 | 11-046 | 12-012 |  | 13-006F | 100 |  |  |  |  |  |  |  | 0 | 83903.9 | 8390390 |  |  | 08-016 | 09-012 | APP | 08-052 |  | 09-022 | 11-025 | 12-036F |  | 12-001 |  |  |  |  |  |  |  |  |  |  |
| 14362016 |  | Produce Drawings - Pivot Sections of Supprt Struct |  | 117d | 2010-06-14 A | 2010-11-29 A | 14362012 | 100% |  |  |  |  |  | MECH DES [320 h]; MECH ENG [160 h] | 25,285.21 | 25,285.21 |  | 0 | 25809.6 | FENKER H | 1 | 1 | H | HOWARD F | 10-069 | 11-026 | 11-046 | 12-012 |  | 13-006F |  |  |  |  |  |  |  |  |  |  |  |  |  |  |  | APP | 08-052 | 4362A | 09-022 | 11-025 | 12-036F |  |  |  |  |  |  |  |  |  |  |  |  |
| 14362047 |  | Procurement Prep - Bogies |  | 51d | 2010-07-15 A | 2010-09-24 A | 14362046, 9-110M FS-20d | 100% |  |  |  |  |  | MECH ENG [80 h] | 5,268 | 5,268 |  | 0 | 5436 | FENKER H | 1 | 1 | H | HOWARD F | 10-069 | 11-026 | 11-046 | 12-012 | 12-054F | 13-006F |  |  |  |  |  |  |  |  |  |  |  |  |  | 08-016 |  | APP | 08-052 | 4362C | 09-022 | 11-025 | 12-036F |  |  |  |  |  |  |  |  |  |  |  |  |
| 14362047a |  | Procurement Prep - Wheels |  | 43d | 2010-08-02 A | 2010-09-30 A | 9-110M FS-20d, 14362046a | 100% |  |  |  |  |  | MECH ENG [80 h] | 5,268 | 5,268 |  | 0 | 5436 | FENKER H | 1 | 1 | H | HOWARD F | 10-069 | 11-026 | 11-046 | 12-012 |  | 13-006F |  |  |  |  |  |  |  |  |  |  |  |  |  | 08-016 |  | APP | 08-052 | 4362C | 09-022 | 11-025 | 12-036F |  |  |  |  |  |  |  |  |  |  |  |  |
| 14362006 |  | SS/SH Engineering Support FY10 |  | 21d | 2010-09-01 A | 2010-09-30 A | 14362005 FS-21d | 100% |  |  |  |  |  | MECH DES [465 h]; MECH ENG [465 h]; PROCUREMENT>$50K 69 | 52,565.9 | 51,656.85 |  | 0 | 52565.9 | FENKER H | 1 | 1 | H | HOWARD F | 10-069 | 11-026 | 11-046 | 12-012 |  |  | 100 |  |  |  |  |  |  |  | 0 | 909.05 | 90905 |  |  | 08-016 | 09-012 | APP | 08-052 | 4362B | 09-022 | 11-025 | 12-036F |  |  |  |  |  |  |  |  |  |  |  |  |
| 14362007 |  | SS/SH Engineering Support FY11 |  | 248d | 2010-10-01 A | 2011-09-30 A | 14362006, 9-110M | 100% |  |  |  |  |  | PROCUREMENT<$50K 60; PROCUREMENT>$50K 69 | 139,306.5 |  |  | 0 | 139306.5 | FENKER H | 1 | 1 | S | HOWARD F | 10-069 | 11-026 | 11-046 | 12-012 |  |  | 100 |  |  | ST |  |  |  |  | 0 | 139306.5 | 13930650 |  |  |  |  | APP |  | 4362B |  | 11-025 | 12-036F |  |  |  |  |  |  |  |  |  |  |  |  |
| 14362811LOE |  | Overlook Various Subcontracts of Supprt Struct |  | 248d | 2010-10-01 A | 2011-09-30 A | 9-110M | 100% |  |  |  |  |  | SCIENTIST [200 h] | 13,686 | 13,686 |  | 0 | 13686 | FENKER H | 1 | 1 | E | HOWARD F | 10-069 | 11-026 | 11-046 |  |  |  |  |  |  |  |  |  |  |  |  |  |  |  |  |  |  |  | 08-052 |  | 09-022 |  |  |  |  | 8.46774193 | 91.53225806 | 100 | 100 |  |  |  |  |  |  |
| 14362010M |  | Review Final Dsgn of Supprt Struct | milestone | 0d | 2010-10-27 A | 2010-10-27 A | 14363010, 14362005, 14362006 FS+19d | 100% | 2010-11-01 | 2010-11-01 |  |  |  |  |  |  |  |  | 0 | FENKER H | 1 | 1 | M | HOWARD F | 10-069 | 11-026 | 11-046 | 12-012 |  | 13-006F |  |  |  |  |  |  |  |  |  |  |  |  |  |  |  |  | 08-052 |  |  | 11-025 | 12-036F | 6 |  |  |  |  |  |  |  |  |  |  |  |
| 14362036 |  | Produce Drawings - Mag Mounts of Supprt Struct |  | 71d | 2010-11-01 A | 2011-02-21 A | 14362041 FS-80d | 100% | 2010-11-01 | 2011-02-18 |  |  |  | MECH DES [320 h]; MECH ENG [160 h] | 25,809.6 | 25,809.6 |  | 0 | 25809.6 | FENKER H | 1 | 1 | H | HOWARD F | 10-069 | 11-026 | 11-046 | 12-012 |  | 13-006F |  |  |  |  |  |  |  |  |  |  |  |  |  |  |  | APP | 08-052 |  | 09-022 | 11-025 | 12-036F |  |  |  |  |  |  |  |  |  |  |  |  |
| 14362013 |  | Procurement Prep - Rails & Base of Supprt Struct |  | 15d | 2010-12-01 A | 2010-12-23 A | 14362012, 14362047 | 100% | 2010-12-01 | 2010-12-21 |  |  |  | MECH ENG [80 h] | 5,436 | 5,436 |  | 0 | 5436 | FENKER H | 1 | 1 | H | HOWARD F | 10-069 | 11-026 | 11-046 | 12-012 | 12-054F | 13-006F |  |  |  |  |  |  |  |  |  |  |  |  |  |  |  | APP | 08-052 |  | 09-022 | 11-025 | 12-036F |  |  |  |  |  |  |  |  |  |  |  |  |
| 14362017 |  | Procurement Prep - Pivot Sections of Supprt Struct |  | 13d | 2011-01-03 A | 2011-01-21 A | 14362013, 14362016 | 100% | 2011-01-04 | 2011-01-21 |  |  |  | MECH ENG [80 h] | 5,436 | 5,436 |  | 0 | 5436 | FENKER H | 1 | 1 | H | HOWARD F | 10-069 | 11-026 | 11-046 | 12-012 |  | 13-006F |  |  |  |  |  |  |  |  |  |  |  |  |  |  |  | APP | 08-052 | 4362A | 09-022 | 11-025 | 12-036F |  |  |  |  |  |  |  |  |  |  |  |  |
| 14362041 |  | Produce Drawings - Access Platforms of Supprt Struct |  | 117d | 2011-02-01 A | 2011-07-18 A | 14362016 | 100% |  |  |  |  |  | MECH DES [320 h]; MECH ENG [160 h] | 25,809.6 | 25,809.6 |  | 0 | 25809.6 | FENKER H | 1 | 1 | H | HOWARD F | 10-069 | 11-026 | 11-046 | 12-012 |  | 13-006F |  |  |  |  |  |  |  |  |  |  |  |  |  | 08-016 |  | APP | 08-052 |  | 09-022 | 11-025 | 12-036F |  |  |  |  |  |  |  |  |  |  |  |  |
| 14362021 |  | Produce Drawings - Mag Section of Supprt Struct |  | 15d | 2011-02-07 A | 2011-02-28 A | 14362031 FS-70d | 100% |  |  |  |  |  | MECH DES [360 h]; MECH ENG [200 h] | 30,394.8 | 30,394.8 |  | 0 | 30394.8 | FENKER H | 1 | 1 | H | HOWARD F | 10-069 | 11-026 | 11-046 | 12-012 |  | 13-006F |  |  |  |  |  |  |  |  |  |  |  |  |  |  |  | APP | 08-052 |  | 09-022 | 11-025 | 12-036F |  |  |  |  |  |  |  |  |  |  |  |  |
| 14362026 |  | Produce Drawings - Detector Section of Supprt Struct |  | 10d | 2011-02-07 A | 2011-02-21 A | 14362036 | 100% | 2011-02-07 | 2011-02-18 |  |  |  | MECH DES [320 h]; MECH ENG [160 h] | 25,809.6 | 25,809.6 |  | 0 | 25809.6 | FENKER H | 1 | 1 | H | HOWARD F | 10-069 | 11-026 | 11-046 | 12-012 |  | 13-006F |  |  |  |  |  |  |  |  |  |  |  |  |  | 08-016 |  | APP | 08-052 |  | 09-022 | 11-025 | 12-036F |  |  |  |  |  |  |  |  |  |  |  |  |
| 14362037 |  | Procurement Prep - Mag Mounts of Supprt Struct |  | 15d | 2011-02-07 A | 2011-02-28 A | 14362042, 14362036 FS+20d | 100% |  |  |  |  |  | MECH ENG [80 h] | 5,436 | 5,436 |  | 0 | 5436 | FENKER H | 1 | 1 | H | HOWARD F | 10-069 | 11-026 | 11-046 | 12-012 |  | 13-006F |  |  |  |  |  |  |  |  |  |  |  |  |  |  |  | APP | 08-052 |  | 09-022 | 11-025 | 12-036F |  |  |  |  |  |  |  |  |  |  |  |  |
| 14362022 |  | Procurement Prep - Mag Section of Supprt Struct |  | 44d | 2011-03-01 A | 2011-04-29 A | 14362032 FS-90d, 14362021 FS-60d | 100% |  |  |  |  |  | MECH ENG [80 h] | 5,436 | 5,436 |  | 0 | 5436 | FENKER H | 1 | 1 | H | HOWARD F | 10-069 | 11-026 | 11-046 | 12-012 |  | 13-006F |  |  |  |  |  |  |  |  |  |  |  |  |  |  |  | APP | 08-052 |  | 09-022 | 11-025 | 12-036F |  |  |  |  |  |  |  |  |  |  |  |  |
| 14362027 |  | Procurement Prep - Detector Section of Supprt Struct |  | 43d | 2011-03-01 A | 2011-04-28 A | 14362026 | 100% |  |  |  |  |  | MECH ENG [80 h] | 5,436 | 5,436 |  | 0 | 5436 | FENKER H | 1 | 1 | H | HOWARD F | 10-069 | 11-026 | 11-046 | 12-012 |  | 13-006F |  |  |  |  |  |  |  |  |  |  |  |  |  | 08-016 |  | APP | 08-052 |  | 09-022 | 11-025 | 12-036F |  |  |  |  |  |  |  |  |  |  |  |  |
| 14362031 |  | Produce Drawings - Wheel Section of Supprt Struct |  | 87d | 2011-03-01 A | 2011-06-30 A | 14362051 FS-40d | 100% |  |  |  |  |  | MECH DES [400 h]; MECH ENG [200 h] | 32,262 | 32,262 |  | 0 | 32262 | FENKER H | 1 | 1 | H | HOWARD F | 10-069 | 11-026 | 11-046 | 12-012 |  | 13-006F |  |  |  |  |  |  |  |  |  |  |  |  |  |  |  |  | 08-052 |  | 09-022 | 11-025 | 12-036F |  |  |  |  |  |  |  |  |  |  |  |  |
| 14362051 |  | Produce Drawings - Other Compnts of Supprt Struct |  | 87d | 2011-03-01 A | 2011-06-30 A | 14362026 | 100% |  |  |  |  |  | MECH ENG [200 h]; MECH DES [400 h] | 32,262 | 32,262 |  | 0 | 32262 | FENKER H | 1 | 1 | H | HOWARD F | 10-069 | 11-026 | 11-046 | 12-012 |  | 13-006F |  |  |  |  |  |  |  |  |  |  |  |  |  |  |  | APP | 08-052 |  | 09-022 | 11-025 | 12-036F |  |  |  |  |  |  |  |  |  |  |  |  |
| 14362032 |  | Procurement Prep - Wheel Section of Supprt Struct |  | 89d | 2011-04-11 A | 2011-08-15 A | 14362052 FS-60d, 14362031 FS-45d | 100% |  |  |  |  |  | MECH ENG [80 h] | 5,436 | 5,436 |  | 0 | 5436 | FENKER H | 1 | 1 | H | HOWARD F | 10-069 | 11-026 | 11-046 | 12-012 |  | 13-006F |  |  |  |  |  |  |  |  |  |  |  |  |  |  |  |  | 08-052 |  | 09-022 | 11-025 | 12-036F |  |  |  |  |  |  |  |  |  |  |  |  |
| 14362052 |  | Procurement Prep - Other Compnts of Supprt Struct |  | 71d | 2011-06-30 A | 2011-10-10 A | 14362027, 14362051 | 100% |  |  |  |  |  | MECH ENG [80 h] | 5,450.67 | 5,450.67 |  | 0 | 5436 | FENKER H | 1 | 1 | H | HOWARD F | 10-069 | 11-026 | 11-046 | 12-012 |  | 13-006F |  |  |  |  |  |  |  |  |  |  |  |  |  |  |  | APP | 08-052 |  | 09-022 | 11-025 | 12-036F |  |  |  |  |  |  |  |  |  |  |  |  |
| 14362042 |  | Procurement Prep - Access Platforms of Supprt Struct |  | 21d | 2011-07-15 A | 2011-08-14 A | 14362017, 14362041 | 100% | 2011-07-15 | 2011-08-12 |  |  |  | MECH ENG [80 h] | 5,436 | 5,436 |  | 0 | 5436 | FENKER H | 1 | 1 | H | HOWARD F | 10-069 | 11-026 | 11-046 | 12-012 |  | 13-006F |  |  |  |  |  |  |  |  |  |  |  |  |  | 08-016 |  | APP | 08-052 |  | 09-022 | 11-025 | 12-036F |  |  |  |  |  |  |  |  |  |  |  |  |
| 14362015 |  | PreFab Rails & Base of Supprt Struct |  | 98d | 2011-08-01 A | 2011-12-19 A | 14362010M FS-130d, 14362013 | 100% |  |  |  |  |  | PROCUREMENT>$50K 69; MECH ENG [80 h]; PROCUREMENT<$50K 60; MECH DES [40 h] | 89,983.7 | 7,431.7 |  | 0 | 90088.4 | FENKER H | 1 | 1 | D | HOWARD F | 10-069 | 11-026 | 11-046 | 12-012 | 12-054F | 13-006F | 100 |  |  |  |  |  |  |  | 0 | 82552 | 8255200 |  |  |  |  | APP | 08-052 |  | 09-022 | 11-025 | 12-036F |  |  |  |  |  |  |  |  |  |  |  |  |
| 14362060 |  | Proc Drive Motors & Reducers of Supprt Struct |  | 23d | 2011-08-01 A | 2011-08-31 A | 9-120M FS+65d, 14362010M | 100% |  |  |  |  |  | MECH ENG [160 h] | 10,872 | 10,872 |  | 0 | 11219.2 | FENKER H | 1 | 1 | H | HOWARD F | 10-069 | 11-026 | 11-046 | 12-012 |  |  |  |  |  |  |  |  |  |  |  |  |  |  |  |  |  |  | 08-052 |  | 09-022 | 11-025 | 12-036F |  |  |  |  |  |  |  |  |  |  |  |  |
| 14362020 |  | PreFab Pivot Sections of Supprt Struct |  | 198d | 2011-08-22 A | 2012-06-11 A | 14362010M, 14362017 | 100% |  |  |  |  |  | TRAVEL; MECH ENG [80 h]; PROCUREMENT<$50K 60; PROCUREMENT>$50K 69 | 73,535.39 | 5,584.17 |  | 0 | 73560.82 | FENKER H | 1 | 1 | D | HOWARD F | 10-069 | 11-026 | 11-046 | 12-012 |  | 13-006F | 100 |  |  |  |  |  |  |  | 0 | 61914 | 6191400 |  |  |  |  | APP | 08-052 | 4362A | 09-022 | 11-025 | 12-036F |  |  |  |  |  |  |  |  |  |  |  |  |
| 14362025 |  | PreFab Mag Section #20 of Supprt Struct |  | 203d | 2011-09-13 A | 2012-07-09 A | 14362022, 14362010M | 100% |  |  |  |  |  | TRAVEL; MECH DES [320 h]; PROCUREMENT<$50K 60; PROCUREMENT>$50K 69; MECH ENG [240 h] | 195,672.34 | 32,174.4 |  | 0 | 195741.14 | FENKER H | 1 | 1 | D | HOWARD F | 10-069 | 11-026 | 11-046 | 12-012 |  | 13-006F | 100 |  |  |  |  |  |  |  | 0 | 157460.72 | 15746072 |  |  |  |  | APP | 08-052 |  | 09-022 | 11-025 | 12-036F |  |  |  |  |  |  |  |  |  |  |  |  |
| 14362030 |  | PreFab Detector Section #30 of Supprt Struct |  | 208d | 2011-09-13 A | 2012-07-16 A | 14362037, 14362027 | 100% |  |  |  |  |  | MECH ENG [80 h]; MECH DES [40 h]; PROCUREMENT>$50K 69 | 172,680.43 | 7,520.71 |  | 0 | 172696.12 | FENKER H | 1 | 1 | D | HOWARD F | 10-069 | 11-026 | 11-046 | 12-012 |  | 13-006F | 100 |  |  |  |  |  |  |  | 0 | 165159.72 | 16515972 |  |  | 08-016 | 09-012 | APP | 08-052 |  | 09-022 | 11-025 | 12-036F |  |  |  |  |  |  |  |  |  |  |  |  |
| 14362035 |  | PreFab Wheel Section of Supprt Struct |  | 110d | 2011-09-13 A | 2012-02-27 A | 14362032, 14362010M | 100% |  |  |  |  |  | PROCUREMENT<$50K 60; MECH ENG [80 h]; TRAVEL; MECH DES [40 h]; PROCUREMENT>$50K 69 | 166,255.85 | 7,506.72 |  | 0 | 166285.53 | FENKER H | 1 | 1 | S | HOWARD F | 10-069 | 11-026 | 11-046 | 12-012 |  | 13-006F | 100 |  |  | ST |  |  |  |  | 0 | 152711.91 | 15271191 |  |  |  |  |  | 08-052 |  | 09-022 | 11-025 | 12-036F |  |  |  |  |  |  |  |  |  |  |  |  |
| 14362011 |  | SS/SH Engineering Support FY12 |  | 247d | 2011-10-03 A | 2012-09-28 A | 14362010M, 14362007, 9-120M | 100% |  |  |  |  |  | PROCUREMENT>$50K 69; PROCUREMENT<$50K 60 | 127,778.11 |  |  | 0 | 127778.11 | FENKER H | 1 | 1 | E | HOWARD F | 10-069 | 11-026 | 11-046 | 12-012 |  |  | 100 |  |  |  |  |  |  |  | 0 | 127778.11 | 12777811 |  |  | 08-016 |  | APP | 08-052 | 4362B | 09-022 | 11-025 | 12-036F |  |  | 7.69230769 | 92.3076923 | 100 | 100 |  |  |  |  |  |  |
| 14362050 |  | PreFab Double Bogies of Supprt Struct |  | 309d | 2011-10-03 A | 2013-02-11 A | 9-120M, 14362047 | 100% | 2011-10-03 | 2013-01-04 |  |  |  | MECH ENG [160 h]; MECH DES [80 h]; PROCUREMENT>$50K 69; PROCUREMENT<$50K 60 | 327,673.35 | 15,198.25 | 14362050 | 0 | 327576.72 | FENKER H | 1 | 1 | D | HOWARD F | 10-069 | 11-026 | 11-046 | 12-012 |  | 13-006F | 100 |  |  |  |  |  |  |  | 0 | 312503.92 | 31250392 |  |  | 08-016 | 09-012 | APP | 08-052 | 4362C | 09-022 | 11-025 | 12-036F |  |  |  |  |  |  | XX |  |  |  |  |  |
| 14362050a |  | PreFab Wheels of Supprt Struct |  | 309d | 2011-10-03 A | 2013-02-11 A | 14362047a, 9-120M, 14362010M | 100% | 2011-10-03 | 2013-01-04 |  |  |  | PROCUREMENT>$50K 69; MECH ENG [80 h]; MECH DES [80 h] | 173,019.96 | 9,541.97 | 14362050a | 0 | 172959.28 | FENKER H | 1 | 1 | D | HOWARD F | 10-069 | 11-026 | 11-046 | 12-012 |  | 13-006F | 100 |  |  |  |  |  |  |  | 0 | 163496.08 | 16349608 |  |  | 08-016 |  | APP | 08-052 | 4362C | 09-022 | 11-025 | 12-036F |  |  |  |  |  |  | XX |  |  |  |  |  |
| 14362055 |  | PreFab Other Compnts of Supprt Struct |  | 69d | 2011-10-03 A | 2012-01-18 A | 9-120M, 14362052, 14362010M | 100% |  |  |  |  |  | PROCUREMENT<$50K 60; MECH ENG [80 h]; MECH DES [80 h] | 71,377.2 | 9,463.2 |  | 0 | 71377.2 | FENKER H | 1 | 1 | D | HOWARD F | 10-069 | 11-026 | 11-046 | 12-012 |  | 13-006F | 100 |  |  |  |  |  |  |  | 0 | 61914 | 6191400 |  |  |  | 09-012 | APP | 08-052 |  | 09-022 | 11-025 | 12-036F |  |  |  |  |  |  |  |  |  |  |  |  |
| 14362812LOE |  | Overlook Various Subcontracts of Supprt Struct |  | 247d | 2011-10-03 A | 2012-09-28 A | 14362811LOE | 100% |  |  |  |  |  | SCIENTIST [200 h] | 14,122 | 14,122 |  | 0 | 14122 | FENKER H | 1 | 1 | E | HOWARD F | 10-069 | 11-026 | 11-046 |  |  |  |  |  |  |  |  |  |  |  |  |  |  |  |  |  |  |  | 08-052 |  | 09-022 |  |  |  |  | 7.69230769 | 92.3076923 | 100 | 100 |  |  |  |  |  |  |
| 14362065 |  | Electrical System Final Drawings |  | 131d | 2012-01-03 A | 2012-07-09 A | 9-120M FS+60d | 100% |  |  |  |  |  | ELEC ENG [160 h]; MECH DES [320 h] | 26,704 | 26,704 |  | 0 | 26704 | FENKER H | 1 | 1 | H | HOWARD F | 10-069 | 11-026 | 11-046 | 12-012 |  |  |  |  |  |  |  |  |  |  |  |  |  |  |  |  |  |  | 08-052 |  | 09-022 | 11-025 | 12-036F |  |  |  |  |  |  |  |  |  |  |  |  |
| 14362035a |  | PreFab #100 section of Support STructure and Inner Race |  | 130d | 2012-01-04 A | 2012-07-09 A | 9-120M FS+59d | 100% |  |  |  |  |  | PROCUREMENT<$50K 60; PROCUREMENT>$50K 69 | 63,000 |  |  | 0 | 63000 | FENKER H | 1 | 1 | D | HOWARD F | 10-069 | 11-026 | 11-046 | 12-012 |  | 13-006F | 100 |  |  |  |  |  |  |  | 0 | 63000 | 6300000 |  |  |  |  |  | 08-052 |  | 09-022 | 11-025 | 12-036F |  |  |  |  |  |  |  |  |  |  |  |  |
| 14362045 |  | PreFab Access Platforms of Supprt Struct |  | 48d | 2012-01-10 A | 2012-03-19 A | 9-120M, 14362042 | 100% |  |  |  |  |  | MECH DES [40 h]; MECH ENG [40 h]; PROCUREMENT<$50K 60 | 87,283.6 | 4,731.6 |  | 0 | 87283.6 | FENKER H | 1 | 1 | D | HOWARD F | 10-069 | 11-026 | 11-046 | 12-012 |  | 13-006F | 100 |  |  |  |  |  |  |  | 0 | 82552 | 8255200 |  |  | 08-016 | 09-012 | APP | 08-052 |  | 09-022 | 11-025 | 12-036F |  |  |  |  |  |  |  |  |  |  |  |  |
| 14362040 |  | PreFab Mag Mounts of Supprt Struct |  | 11d | 2012-03-05 A | 2012-03-19 A | 9-120M FS+144d, 14362037 | 100% |  |  |  |  |  | MECH ENG [40 h] | 2,804.8 | 2,804.8 |  | 0 | 2804.8 | FENKER H | 1 | 1 | H | HOWARD F | 10-069 | 11-026 | 11-046 | 12-012 |  | 13-006F |  |  |  |  |  |  |  |  |  |  |  |  |  |  |  |  | 08-052 |  | 09-022 | 11-025 | 12-036F |  |  |  |  |  |  |  |  |  |  |  |  |
| 14362070 |  | Fire Safety and HVAC Final Drawings |  | 69d | 2012-04-02 A | 2012-07-09 A | 9-120M FS+105d | 100% |  |  |  |  |  | MECH DES [160 h]; PLANT ENG [80 h] | 13,326.4 | 13,326.4 |  | 0 | 13326.4 | FENKER H | 1 | 1 | H | HOWARD F | 10-069 | 11-026 | 11-046 | 12-012 |  |  |  |  |  |  |  |  |  |  |  |  |  |  |  |  |  |  | 08-052 |  | 09-022 | 11-025 | 12-036F |  |  |  |  |  |  |  |  |  |  |  |  |
| 14362950 |  | Re-Baseline Actuals Adjustment |  | 1d | 2013-08-30 A | 2013-08-30 A |  | 100% | 2013-09-03 | 2013-09-03 |  |  |  | PROCUREMENT>$50K 69 NO ESCALATION | -157,840.37 |  |  |  |  |  |  |  |  |  |  |  |  |  |  |  | 100 | ADJ |  |  |  |  |  |  |  |  |  |  |  |  |  |  |  |  |  |  |  |  |  |  |  |  |  |  |  |  |  |  |  |
| 24362000 |  | Engineering Consulting |  | 20d | 2013-09-03 A | 2013-09-16 A | 9-130M FS+228d | 100% | 2013-09-03 | 2013-09-30 |  |  | 8/5 M-F w/JLAB Holidays ReBaseline | PROCUREMENT>$50K 69 NO ESCALATION FY14 | 1,519.7 |  |  |  | 0 | FENKER H | 1 | 1 | U | HOWARD F | 10-069 | 11-026 | 11-046 | 12-012 |  | 13-006F | 100 |  | 24363030aa |  |  | 13-015 | PR |  | 0 | 1519.7 | 151970 | EJ |  |  |  | APP | 08-052 | 4362B | 09-022 | 11-025 |  |  |  |  |  |  |  |  | PR in system | 1519.7 | 10-025 | 12-055 | OB |

Notes:
- 24355000: Steps: Downstream beam-line layout for startup determined & frozen.; Detailing of Pipe Sections complete; Detailing of connections / fittings / flanges complete for PR's; Stands, Supports, Brackets, etc. final specs done; All hardware detailing complete for PR's
- 14362005: Steps: Draft Design Drawings Done (done); Draft CAD Models Done (done); Incorporate Boron Shielding in Design (done); Draft FEA Analysis (done); Commerical Components List (done); PDR - Final Design Outline (done); Structural Optimization Complete (done); FDR - Review of Draft Deliverables (done); CAD Drawings & 3D Model (done); Engineering Analysis Report (done); On-Site Assembly Plan (done); Final Design Report (done)
- 14362007: Steps: Welding and Design Detail Content (done); Weld Process Specifications (done); Provide Cost Estimate (done); Review and Check JLab 3D Cad Model (done); Revision of FEA (done); Analyze/Check Drawing Package #1 (done); Analyze/Check Drawing Package #2 (done); Analyze/Check Drawing Package #3 (done); Analyze/Check Drawing Package #4 (done); Analyze/Check Drawing Package #5 (done); Analyze/Check Drawing Package #6 (done); Analyze/Check Drawing Package #7 (done); Analyze/Check Drawing Package #8 (done)
- 14362035: Steps: Material Procurement (done); Fabricate Section 40 (done); Fabricate Section 50 (done); Fabricate Section 60 (done); Prepare/Mask/Blast and Paint Sec. 40 (done); Prepare/Mask/Blast and Paint Sec. 50 (done); Prepare/Mask/Blast and Paint Sec. 60 (done); Deliver Section 40 (done); Deliver Section 50 (done); Deliver Section 60 (done)

| ID | WBS | Activity | Type | Duration | Start | Finish | Predecessors | Complete | Remaining | Planned start | Planned finish | Total float | Free float | Calendar | Resources | Cost | Actual cost | Remaining Material Cost Based on % Compl | Claimed Material Cost Based on % Complet | Initial Claimed Material Calc | Claimed Material Divider | Calculated Remaining Total Cost | MONTHLY EV COST | RESP - Responsibility | STRT%COMP for CM EVM | FNSH%COMP for CM EVM | Advance Purchase Plan > 500K | EVMS Reporting Codes | CAM RESPONSIBLE | CR 08-052 | 12 GEV MAJOR PROCUREMENT CATAGORY | Activities with Steps | CR 09-012 | CR 09-022 | CR 10-025 | CR 10-069 | CR 11-025 | CR 11-026 | CR 11-046 | CR 12-012 | CR 12-036 | CR 13-006 | Milestone Level | Specification | CR 12-001 | CR 12-055 | MARCH!!! | CR 12-054 | CR 08-016 | ReBaseline Actuals Adjustment | BOE NOTES | Original Activity ID Rebaseline | PRIOR MONTH EV COST | BOE Procurement | CR 13-015 | Post Rebaseline | Obligated Prior to Rebaseline | BOE Labor | CR 14-001 | BOE Expenses | CR 12-053 | CR 12-022 | Howard's Code |
| --- | --- | --- | --- | --- | --- | --- | --- | --- | --- | --- | --- | --- | --- | --- | --- | --- | --- | --- | --- | --- | --- | --- | --- | --- | --- | --- | --- | --- | --- | --- | --- | --- | --- | --- | --- | --- | --- | --- | --- | --- | --- | --- | --- | --- | --- | --- | --- | --- | --- | --- | --- | --- | --- | --- | --- | --- | --- | --- | --- | --- | --- | --- | --- |
|  | 3 | **1.4.3.6.3 SHIELD HOUSE** |  |  | 2010-03-29 | 2014-01-30 |  |  |  |  |  |  |  |  |  |  |  |  |  |  |  |  |  |  |  |  |  |  |  |  |  |  |  |  |  |  |  |  |  |  |  |  |  |  |  |  |  |  |  |  |  |  |  |  |  |  |  |  |  |  |  |  |  |
| 14363010 |  | Finalize Dsgn of Shield House (SHIELD HOUSE) |  | 130d | 2010-03-29 A | 2010-09-30 A | 14362005 FS-130d, 14363005M | 100% |  | 2010-03-29 | 2010-09-29 |  |  |  | PROCUREMENT<$50K 60; TRAVEL; MECH ENG [341.54 h]; MECH DES [341.54 h] | 56,176.89 | 37,941.68 | 0 | 13394.31 | 1339431 | 100 | 0 | 56176.8886 | FENKER H | 1 | 1 | APP | S | HOWARD F | 08-052 | 4362B | ST | 09-012 | 09-022 | 10-025 | 10-069 | 11-025 | 11-026 | 11-046 | 12-012 | 12-036F | 13-006F |  |  |  |  |  |  |  |  |  |  |  |  |  |  |  |  |  |  |  |  |  |
| 14363005M |  | Award Contract for Final Dsgn of Shield House (SHIELD HOUSE) | milestone | 0d | 2010-04-29 A | 2010-04-29 A | 12236060, 9-100M FS+142d | 100% |  | 2010-05-03 | 2010-05-03 |  |  |  |  |  |  |  |  |  |  |  | 0 | FENKER H | 1 | 1 |  | M | HOWARD F | 08-052 |  |  |  |  |  | 10-069 | 11-025 | 11-026 | 11-046 | 12-012 | 12-036F | 13-006F | 6 |  |  |  |  |  |  |  |  |  |  |  |  |  |  |  |  |  |  |  |  |
| 14363021 |  | Produce Drawings - Steel (SHIELD HOUSE) FY11 |  | 369.4d | 2011-04-25 A | 2012-10-15 A | 14362021 | 100% |  |  |  |  |  |  | MECH DES [603.87 h]; MECH ENG [301.94 h] | 49,834.22 | 49,834.22 |  |  |  |  | 0 | 48705.4746 | FENKER H | 1 | 1 | APP | S | HOWARD F | 08-052 |  | ST |  | 09-022 |  | 10-069 | 11-025 | 11-026 | 11-046 | 12-012 | 12-036F |  |  | 14363021 | 12-001 |  |  |  |  |  |  |  |  |  |  |  |  |  |  |  |  |  |  |
| 14363021a |  | Produce Drawings - Steel (SHIELD HOUSE) FY12 |  | 370d | 2011-04-25 A | 2012-10-15 A | 14363021 FS-110d | 100% |  |  |  |  |  |  | MECH ENG [218.06 h]; MECH DES [436.13 h] | 35,993.29 | 35,993.29 |  |  |  |  | 0 | 36298.7493 | FENKER H | 1 | 1 | APP | S | HOWARD F | 08-052 |  | ST | 09-012 | 09-022 |  | 10-069 | 11-025 | 11-026 | 11-046 | 12-012 | 12-036F |  |  | 14363021a | 12-001 |  |  |  |  |  |  |  |  |  |  |  |  |  |  |  |  |  |  |
| 14363030 |  | Proc Boron and Lead Shielding (SHIELD HOUSE) Part A |  | 207d | 2012-04-02 A | 2013-04-15 A | 14363021a FS-100d | 100% |  | 2012-04-02 | 2013-01-31 |  |  |  | PROCUREMENT<$50K 60; PROCUREMENT>$50K 69 | 531,428.5 |  | 0 | 531428.5 | 53142850 | 100 | 0 | 531428.5 | FENKER H | 1 | 1 | APP | S | HOWARD F | 08-052 | 4362B | ST |  | 09-022 | 10-025 | 10-069 | 11-025 | 11-026 | 11-046 | 12-012 |  |  |  |  |  | 12-055 | XX |  |  |  |  |  |  |  |  |  |  |  |  |  |  |  |  |
| 14363022 |  | Procurement Prep - Steel (SHIELD HOUSE) |  | 11d | 2012-11-03 A | 2012-11-19 A | 14363021a FS-20d | 100% |  | 2012-11-05 | 2012-11-19 |  |  |  | MECH ENG [80 h] | 5,788.8 | 5,788.8 |  |  |  |  | 0 | 5609.6 | FENKER H | 1 | 1 | APP | H | HOWARD F | 08-052 |  |  |  | 09-022 |  | 10-069 | 11-025 | 11-026 | 11-046 | 12-012 | 12-036F |  |  | 14363022 |  |  |  |  |  |  |  |  |  |  |  |  |  |  |  |  |  |  |  |
| 14363025 |  | Fab Steel Supprt (SHIELD HOUSE) |  | 8d | 2012-11-08 A | 2012-11-19 A | 9-120M, 14363022, 14362010M | 100% |  |  |  |  |  |  | MECH DES [160 h]; MECH TECH [160 h]; MECH ENG [160 h] | 26,868.8 | 26,868.8 |  |  |  |  | 0 | 26036.8 | FENKER H | 1 | 1 | APP | P | HOWARD F | 08-052 |  |  | 09-012 | 09-022 |  | 10-069 | 11-025 | 11-026 | 11-046 | 12-012 | 12-036F |  |  | 14363025 |  |  |  |  |  |  |  |  |  |  |  |  |  |  |  |  |  |  |  |
| 14363030a |  | Proc Boron and Lead Shielding (SHIELD HOUSE) Part B |  | 120d | 2013-01-28 A | 2013-08-19 A | 14363021a | 100% |  | 2013-02-11 | 2013-07-31 |  |  |  | PROCUREMENT>$50K 69 | 61,914 |  | 0 | 61914 | 6191400 | 100 | 18574.2 | 61914 | FENKER H | 1 | 1 | APP | S | HOWARD F | 08-052 | 4362B | ST |  | 09-022 | 10-025 | 10-069 | 11-025 | 11-026 | 11-046 | 12-012 |  |  |  |  |  | 12-055 |  |  |  |  |  |  |  |  |  |  |  |  |  |  |  |  |  |
| 14363021b |  | Produce Drawings FY13 |  | 147d | 2013-04-01 A | 2013-08-26 A | 9-130M FS+110d, 14368325 FS+15d | 100% |  | 2013-05-01 | 2013-11-26 |  |  |  | MECH DES [640 h] | 32,098.22 | 31,814.4 |  |  |  |  | 19088.64 | 31814.4 | FENKER H | 1 | 1 | APP | U | HOWARD F |  |  |  |  |  |  |  |  |  |  |  |  | 13-006 |  |  |  |  |  |  |  |  |  |  |  |  |  |  |  |  |  |  |  |  |  |
| 14363035 |  | Fab Doors and associated hardware for Shield House (SHIELD HOUSE) |  | 32d | 2013-04-19 A | 2013-08-30 A |  | 100% |  | 2013-11-06 | 2013-12-30 |  |  |  | PROCUREMENT>$50K 69; PROCUREMENT<$50K 60; MECH DES; PROCUREMENT<$50K 60 NO ESCALATION FY14; PROCUREMENT>$50K 69 NO ESCALATION FY14 |  |  |  |  |  |  | 100875.2 | 0 | FENKER H | 1 | 1 | APP | P | HOWARD F | 08-052 |  |  |  | 09-022 |  | 10-069 | 11-025 | 11-026 | 11-046 |  | 12-036 | 13-006 |  | 14363035 |  |  |  | 12-054 |  |  |  |  |  |  |  |  |  |  |  |  |  |  |  |
| 14363060 |  | Fab Various Small Components (SHIELD HOUSE) |  | 65d | 2013-08-30 A | 2013-08-30 A | 14363030a, 14363030 | 100% |  | 2013-09-03 | 2013-12-04 |  |  |  | MECH ENG [80 h]; MSHOP; PROCUREMENT<$50K 60 | 45,565.44 | 5,788.8 | 0 | 7243.99 | 724399 | 100 | 45437.5 | 45437.5 | FENKER H | 1 | 1 | APP | H | HOWARD F | 08-052 |  |  | 09-012 | 09-022 |  | 10-069 | 11-025 | 11-026 | 11-046 |  |  |  |  | 14363060 |  |  |  |  | 08-016 |  |  |  |  |  |  |  |  |  |  |  |  |  |  |
| 14363065 |  | Re-Baseline Actuals Adjustment |  | 1d | 2013-08-30 A | 2013-08-30 A |  | 100% |  | 2013-09-03 | 2013-09-03 |  |  |  | PROCUREMENT>$50K 69 NO ESCALATION | -28,609.09 |  |  |  |  | 100 |  |  |  |  |  |  |  |  |  |  |  |  |  |  |  |  |  |  |  |  |  |  |  |  |  |  |  |  | ADJ |  |  |  |  |  |  |  |  |  |  |  |  |  |
| 24363030aa |  | Assemble Cast Panels and Lead Sheets (SHIELD HOUSE) |  | 77d | 2013-09-03 A | 2013-10-21 A | 9-130M FS+228d | 100% |  | 2013-09-03 | 2013-12-20 |  |  | 8/5 M-F w/JLAB Holidays ReBaseline | PROCUREMENT>$50K 69 NO ESCALATION FY14 | 7,775 |  | 0 | 7775 | 777500 | 100 |  | 0 | FENKER H | 1 | 1 | APP | U | HOWARD F | 08-052 | 4362B |  |  | 09-022 | 10-025 | 10-069 | 11-025 | 11-026 | 11-046 | 12-012 |  | 13-006F |  |  |  | 12-055 |  |  |  |  | PR in system | 24363030aa | 7775 | EJ | 13-015 | PR | OB |  |  |  |  |  |  |
| 24363035 |  | Fab Doors and associated hardware for Shield House (SHIELD HOUSE) Part A |  | 77d | 2013-09-03 A | 2013-12-20 | 9-130M SS+228d | 34% | 34d |  |  | 209d | 20d | 8/5 M-F w/JLAB Holidays ReBaseline | PROCUREMENT<$50K 60 NO ESCALATION FY14 | 15,589.85 |  | 10289.301 | 5300.549 | 530054.9 | 100 |  | 0 | FENKER H | 1 | 1 | APP | D | HOWARD F | 08-052 |  |  |  | 09-022 |  | 10-069 | 11-025 | 11-026 | 11-046 |  | 12-036 | 13-006 |  |  |  |  |  | 12-054 |  |  |  | 24363035 | 5300.549 | EJ | 13-015 | PR | OB | EJ |  |  |  |  |  |
| 24363036 |  | Fab Doors and associated hardware for Shield House (SHIELD HOUSE) Part B |  | 77d | 2013-09-03 A | 2013-10-21 A | 9-130M SS+228d | 100% |  | 2013-09-03 | 2013-12-20 |  |  | 8/5 M-F w/JLAB Holidays ReBaseline | PROCUREMENT<$50K 60 NO ESCALATION FY14 | 1,987 |  | 0 | 1987 | 198700 | 100 |  | 1987 | FENKER H | 1 | 1 | APP | D | HOWARD F | 08-052 |  |  |  | 09-022 |  | 10-069 | 11-025 | 11-026 | 11-046 |  | 12-036 | 13-006 |  |  |  |  |  | 12-054 |  |  |  | 24363035 |  | EJ | 13-015 | PR | OB | EJ |  |  |  |  |  |
| 24363041 |  | Plastic Pellets |  | 20d | 2013-09-03 A | 2013-10-21 A | 9-130M SS+228d | 100% |  | 2013-09-03 | 2013-09-30 |  |  | 8/5 M-F w/JLAB Holidays ReBaseline | PROCUREMENT<$50K 60 NO ESCALATION FY14 | 1,948.95 |  | 0 | 1948.95 | 194895 | 100 |  | 1948.95 | FENKER H | 1 | 1 | APP | D | HOWARD F | 08-052 |  |  |  | 09-022 |  | 10-069 | 11-025 | 11-026 | 11-046 |  | 12-036 | 13-006 |  |  |  |  |  | 12-054 |  |  |  | 24363035 |  | EJ | 13-015 | PR | OB | EJ |  |  |  |  |  |
| 24363046 |  | Rental Containers for Plastic Pellets |  | 20d | 2013-09-03 A | 2013-12-20 | 9-130M FS+228d |  | 34d | 2013-09-03 | 2013-09-30 | 494d |  | 8/5 M-F w/JLAB Holidays ReBaseline | PROCUREMENT<$50K 60 NO ESCALATION FY14 | 335.62 |  | 335.62 | 0 | 0 | 100 |  | 0 | FENKER H | 1 | 1 | APP | D | HOWARD F | 08-052 |  |  |  | 09-022 |  | 10-069 | 11-025 | 11-026 | 11-046 |  | 12-036 | 13-006 |  |  |  |  |  | 12-054 |  |  |  | 24363035 |  | EJ | 13-015 | PR | OB | EJ |  |  |  |  |  |
| 24363037 |  | Fab Doors and associated hardware for Shield House (SHIELD HOUSE) Part C Procurement |  | 19d | 2013-10-01 A | 2014-01-30 | 9-130M SS+228d | 16% | 54d | 2014-01-03 | 2014-01-30 | 189d | 0d | 8/5 M-F w/JLAB Holidays ReBaseline | PROCUREMENT<$50K 60 NO ESCALATION FY14 | 8,111.15 |  | 6813.366 | 1297.784 | 129778.4 | 100 |  | 1297.784 | FENKER H | 1 | 1 | APP | D | HOWARD F | 08-052 |  |  |  | 09-022 |  | 10-069 | 11-025 | 11-026 | 11-046 |  | 12-036 | 13-006 |  |  |  |  |  | 12-054 |  |  |  | 24363035 |  | EJ | 13-015 | PR | OB-2 | EJ |  |  |  |  |  |
| 24363037a |  | Fab Doors and associated hardware for Shield House (SHIELD HOUSE) Part C Labor FY13 |  | 19d | 2013-10-01 A | 2014-01-30 | 9-130M | 16% | 54d | 2014-01-03 | 2014-01-30 | 189d | 0d | 8/5 M-F w/JLAB Holidays ReBaseline | MECH DES [15.67 h] | 803.87 | 240.12 |  |  |  |  |  | 124.632912 | FENKER H | 1 | 1 | APP | D | HOWARD F | 08-052 |  |  |  | 09-022 |  | 10-069 | 11-025 | 11-026 | 11-046 |  | 12-036 | 13-006 |  |  |  |  |  | 12-054 |  |  |  | 24363035 |  | EJ | 13-015 | PR |  | EJ |  |  |  |  |  |
| 24363037b |  | Fab Doors and associated hardware for Shield House (SHIELD HOUSE) Part C Labor FY14 |  | 77d | 2013-10-01 A | 2014-01-30 | 24363037a FS-54d | 16% | 54d | 2014-01-03 | 2014-04-22 | 189d | 0d | 8/5 M-F w/JLAB Holidays ReBaseline | MECH DES [60.33 h] | 3,094.93 | 924.46 |  |  |  |  |  | 495.18864 | FENKER H | 1 | 1 | APP | D | HOWARD F | 08-052 |  |  |  | 09-022 |  | 10-069 | 11-025 | 11-026 | 11-046 |  | 12-036 | 13-006 |  |  |  |  |  | 12-054 |  |  |  | 24363035 |  | EJ | 13-015 | PR |  | EJ | 14-001 |  |  |  |  |
| 24363060 |  | Fab Various Small Components (SHIELD HOUSE) |  | 34d | 2013-11-18 | 2014-01-16 | 24363030aa FS+20d |  |  |  |  | 401d | 357d | 8/5 M-F w/JLAB Holidays ReBaseline | PROCUREMENT<$50K 60; MECH ENG [80 h]; MSHOP | 46,887.09 |  | 7475.07 | 0 | 0 | 100 |  | 0 | FENKER H | 1 | 1 | APP | D | HOWARD F | 08-052 |  |  | 09-012 | 09-022 |  | 10-069 | 11-025 | 11-026 | 11-046 |  |  | 13-006F |  |  |  |  |  |  | 08-016 |  |  | 24363060 |  | EJ | 13-015 | PR |  | EJ | 14-001 | EJ |  |  |  |
|  | 4 | **1.4.3.6.4 CRYOGENIC SYSTEM** |  |  | 2010-06-01 | 2014-03-20 |  |  |  |  |  |  |  |  |  |  |  |  |  |  |  |  |  |  |  |  |  |  |  |  |  |  |  |  |  |  |  |  |  |  |  |  |  |  |  |  |  |  |  |  |  |  |  |  |  |  |  |  |  |  |  |  |  |
| 14364005 |  | Update Overall Cryo Flow Sheet (CRYO SYS) |  | 64d | 2010-06-01 A | 2010-08-30 A | 12236015b, 9-110M FS-65d | 100% |  |  |  |  |  |  | MECH DES [160 h]; MECH ENG [80 h] | 12,506.4 | 12,506.4 |  |  |  |  | 0 | 12904.8 | FENKER H | 1 | 1 |  | H | HOWARD F |  |  |  |  |  |  | 10-069 |  | 11-026 | 11-046 | 12-012 | 12-036F |  |  |  |  |  |  |  |  |  |  |  |  |  |  |  |  |  |  |  |  |  |  |
| 14364035 |  | Fab Jlab U-tubes (CRYO SYS) |  | 358d | 2010-11-01 A | 2012-04-16 A | 9-110M, 14364030 FS-500d | 100% |  |  |  |  |  |  | MECH DES [120 h]; MECH ENG [40 h]; PROCUREMENT<$50K 60 | 51,882.5 | 8,416.79 | 0 | 43465.71 | 4346571 | 100 | 0 | 52050.91 | FENKER H | 1 | 1 |  | H | HOWARD F |  |  |  |  | 09-022 |  | 10-069 |  | 11-026 | 11-046 | 12-012 | 12-036F |  |  |  |  |  |  |  |  |  |  |  |  |  |  |  |  |  |  |  |  |  |  |
| 14364025 |  | Fab SHMS Distrbtn Transfer Line (CRYO SYS) |  | 335d | 2010-12-06 A | 2012-04-16 A | 14364020a FS-305d, 14364020b FS-300d | 100% |  |  |  |  |  |  | PLABOR; MECH TECH [320 h]; MECH ENG [160 h] | 50,315.63 | 24,961.6 |  |  |  |  | 0 | 50794.03 | FENKER H | 1 | 1 |  | S | HOWARD F |  |  | ST |  | 09-022 |  | 10-069 | 11-025 | 11-026 | 11-046 | 12-012 | 12-036F |  |  |  |  |  |  |  |  |  |  |  |  |  |  |  |  |  |  |  |  |  |  |
| 14364040 |  | Fab Jlab L tubes (CRYO SYS) |  | 282d | 2011-03-01 A | 2012-04-16 A | 14364030 FS-500d | 100% |  |  |  |  |  |  | MECH ENG [40 h]; MECH DES [160 h]; PROCUREMENT>$50K 69 | 34,486.8 | 10,337.87 | 0 | 24148.93 | 2414893 | 100 | 0 | 34660.93 | FENKER H | 1 | 1 |  | S | HOWARD F |  |  | ST |  | 09-022 |  | 10-069 |  | 11-026 | 11-046 | 12-012 | 12-036F |  |  |  |  |  |  |  |  |  |  |  |  |  |  |  |  |  |  |  |  |  |  |
| 14364020 |  | Proc SHMS Distrbtn Transfer Line and Relief Stacks (CRYO SYS) FY12 |  | 220d | 2012-02-13 A | 2012-12-17 A | 14364010 FS-225d | 100% |  | 2012-02-13 | 2012-12-31 |  |  |  | TRAVEL | 5,427.24 |  |  |  |  |  | 0 | 5427.24 | FENKER H | 1 | 1 |  | D | HOWARD F |  |  |  |  |  |  | 10-069 | 11-025 | 11-026 | 11-046 | 12-012 | 12-036F |  |  |  |  |  |  |  |  |  |  |  |  |  |  |  |  |  |  |  | 12-053 |  |  |
| 14364020a |  | Proc SHMS Distrbtn Transfer Line and Relief Stacks (CRYO SYS) FY13 |  | 220d | 2012-02-13 A | 2012-12-17 A | 14364020 FS-160d | 100% |  | 2012-02-13 | 2012-12-31 |  |  |  | TRAVEL | 1,257.26 |  |  |  |  |  | 0 | 1257.26 | FENKER H | 1 | 1 |  | D | HOWARD F |  |  |  |  |  |  | 10-069 | 11-025 | 11-026 | 11-046 | 12-012 | 12-036F |  |  |  |  |  |  |  |  |  |  |  |  |  |  |  |  |  |  |  | 12-053 |  |  |
| 14364020b |  | Proc SHMS Distrbtn Transfer Line and Relief Stacks (CRYO SYS) Procurement |  | 220d | 2012-02-13 A | 2012-12-17 A | 14364010 FS-225d | 100% |  | 2012-02-13 | 2012-12-31 |  |  |  | PROCUREMENT<$50K 60 NO ESCALATION FY13; PROCUREMENT>$50K 69 NO ESCALATION FY13 | 330,000 |  | 0 | 330000 | 33000000 | 100 | 0 | 330000 | FENKER H | 1 | 1 |  | D | HOWARD F |  |  |  |  |  |  | 10-069 | 11-025 | 11-026 | 11-046 | 12-012 | 12-036F |  |  |  |  |  |  |  |  |  |  |  |  |  |  |  |  |  |  |  | 12-053 |  |  |
| 14364015 |  | Detail Mods of G0 Transfer Line |  | 113d | 2012-04-09 A | 2012-09-17 A | 14364010 FS-120d | 100% |  |  |  |  |  |  | MECH DES [48 h]; MECH ENG [24 h]; MECH TECH [48 h] | 6,128.16 | 6,128.16 |  |  |  |  | 0 | 6128.16 | FENKER H | 1 | 1 |  | H | HOWARD F |  |  |  |  |  |  | 10-069 |  | 11-026 | 11-046 | 12-012 | 12-036F | 13-006F |  |  |  |  |  |  |  |  |  |  |  |  |  |  |  |  |  |  |  |  |  |
| 14364045 |  | Proc Valves & Controllers (CRYO SYS) |  | 40d | 2012-10-01 A | 2013-03-11 A | 14364030 FS-160d, 9-130M, 14364043 FS-110d | 100% |  | 2012-10-01 | 2012-11-27 |  |  |  | MECH ENG [40 h]; PROCUREMENT<$50K 60 | 32,799.95 | 2,894.4 | 0 | 29905.55 | 2990555 | 100 | 0 | 32799.95 | FENKER H | 1 | 1 |  | D | HOWARD F |  |  |  |  | 09-022 |  | 10-069 |  | 11-026 | 11-046 | 12-012 | 12-036F | 13-006 |  | 14364045 |  |  |  |  |  |  |  |  |  |  |  |  |  |  |  |  |  | 12-022 |  |
| 14364055 |  | Proc Vac Gauges (CRYO SYS) |  | 40d | 2012-10-01 A | 2012-11-12 A | 14364030 FS-160d, 14364043, 9-130M | 100% |  | 2012-10-01 | 2012-11-27 |  |  |  | PROCUREMENT<$50K 60 | 14,946.73 |  | 0 | 14946.73 | 1494673 | 100 | 0 | 14946.73 | FENKER H | 1 | 1 |  | D | HOWARD F |  |  |  |  | 09-022 |  | 10-069 |  | 11-026 | 11-046 | 12-012 | 12-036F | 13-006 |  |  |  |  |  |  |  |  |  |  |  |  |  |  |  |  |  |  |  | 12-022 |  |
| 14364060 |  | Fab Stand & Catwalk (CRYO SYS) |  | 14d | 2012-11-05 A | 2012-11-26 A | 14364030 | 100% |  |  |  |  |  |  |  |  |  |  |  |  |  |  | 0 | FENKER H | 1 | 1 |  | Z | HOWARD F |  |  |  |  | 09-022 |  | 10-069 |  | 11-026 | 11-046 | 12-012 | 12-036F |  |  | 14364060 |  |  |  |  |  |  |  |  |  |  |  |  |  |  |  |  |  |  |  |
| 14364010 |  | Proc Equipmnt for Mod of G0 Transfer Line (CRYO SYS) |  | 88d | 2012-11-12 A | 2013-08-30 A | 9-130M FS+25d, 9-120M FS+215d, 14364005 | 100% |  | 2012-11-12 | 2013-03-27 |  |  |  | PROCUREMENT>$50K 69 | 36,223.38 |  | 0 | 36223.38 | 3622338 | 100 | 18111.69 | 36223.38 | FENKER H | 1 | 1 |  | D | HOWARD F |  |  |  |  |  |  | 10-069 |  | 11-026 | 11-046 | 12-012 | 12-036F |  |  |  |  |  |  |  |  |  |  |  |  |  |  |  |  |  |  |  |  |  |  |
| 14364050 |  | Proc Boom Supprt (CRYO SYS) |  | 60d | 2013-01-28 A | 2013-04-15 A | 14364030 FS-85d, 14364043 FS-110d, 9-130M | 100% |  | 2013-06-25 | 2013-09-18 |  |  |  | PROCUREMENT<$50K 60 | 20,681.56 |  | 0 | 20681.56 | 2068156 | 100 | 0 | 20681.56 | FENKER H | 1 | 1 |  | D | HOWARD F |  |  |  |  | 09-022 |  | 10-069 |  | 11-026 | 11-046 | 12-012 | 12-036F | 13-006 |  |  |  |  |  |  |  |  |  |  |  |  |  |  |  |  |  |  |  | 12-022 |  |
| 14364030 |  | Fab SHMS Gas Manifolds (CRYO SYS) |  | 60d | 2013-04-01 A | 2013-08-30 A | 14364025 FS+130d, 9-130M FS+120d | 100% |  | 2013-05-01 | 2013-07-25 |  |  |  | TRAVEL; MECH ENG [80 h]; MECH DES [80 h]; MECH TECH [160 h]; PROCUREMENT<$50K 60 | 53,326.57 | 17,103.2 | 0 | 30186.15 | 3018615 | 100 | 52796.97 | 52796.97 | FENKER H | 1 | 1 |  | S | HOWARD F |  |  | ST | 09-012 | 09-022 |  | 10-069 |  | 11-026 | 11-046 | 12-012 | 12-036F |  |  | 14364030 |  |  |  |  | 08-016 |  |  |  |  |  |  |  |  |  |  |  |  |  |  |
| 14364043 |  | Produce Drawings for Cryo System Connections & Controls |  | 39d | 2013-06-01 A | 2013-08-30 A | 9-130M FS+163.15d | 100% |  | 2013-07-01 | 2013-08-23 |  |  |  | MECH DES [320 h]; MECH ENG [320 h] | 39,062.4 | 39,062.4 |  |  |  |  | 39062.4 | 39062.4 | FENKER H | 1 | 1 |  | S | HOWARD F |  |  | ST |  |  |  |  |  |  |  |  |  | 13-006 |  |  |  |  |  |  |  |  |  |  |  |  |  |  |  |  |  |  |  |  |  |
| 14364065 |  | Proc Cables,panels & Pwr Supplies (CRYO SYS) |  | 40d | 2013-06-01 A | 2013-08-30 A | 9-130M FS+144d | 100% |  | 2013-07-01 | 2013-08-26 |  |  |  | MECH DES [80 h]; PROCUREMENT<$50K 60; MECH ENG [80 h] | 22,225.25 | 9,765.6 | 0 | 12459.65 | 1245965 | 100 | 22225.25 | 22225.25 | FENKER H | 1 | 1 |  | D | HOWARD F |  |  |  |  | 09-022 |  | 10-069 |  | 11-026 | 11-046 | 12-012 | 12-036F |  |  | 14364065 |  |  |  | 12-054 |  |  |  |  |  |  |  |  |  |  |  |  |  |  |  |
| 14364016 |  | Modify G0 Transfer Line |  | 107d | 2013-08-30 A | 2013-08-30 A | 14364015, 14368175 FS+48d | 100% |  | 2013-12-19 | 2014-05-29 |  |  |  | MECH TECH [1235.89 h]; MECH DES [349.46 h]; MECH ENG [25.57 h] | 78,318.92 | 75,899.82 |  |  |  |  | 142478.24 | 75899.816932 | FENKER H | 1 | 1 |  | U | HOWARD F |  |  |  |  |  |  | 10-069 |  | 11-026 | 11-046 | 12-012 | 12-036F | 13-006 |  | 14364016 |  |  |  | 12-054 |  |  |  |  |  |  |  |  |  |  |  |  |  |  |  |
| 14364075 |  | Proc & Fab Various Connections etc (CRYO SYS) |  | 50d | 2013-08-30 A | 2013-08-30 A | 14364030, 9-130M FS+80d, 14364043 | 100% |  | 2013-10-25 | 2014-01-14 |  |  |  | SUPPLIES & MATERIALS; MECH ENG [40 h]; PROCUREMENT>$50K 69 | 58,560.15 | 2,894.4 | 0 | 36883.9 | 3688390 | 100 | 58467.75 | 58467.75 | FENKER H | 1 | 1 |  | H | HOWARD F |  |  |  | 09-012 | 09-022 |  | 10-069 |  | 11-026 | 11-046 | 12-012 | 12-036F | 13-006 |  | 14364075 |  |  |  |  | 08-016 |  |  |  |  |  |  |  |  |  |  |  |  | 12-022 |  |
| 14364080 |  | Re-Baseline Actuals Adjustment |  | 1d | 2013-08-30 A | 2013-08-30 A |  | 100% |  | 2013-09-03 | 2013-09-03 |  |  |  | PROCUREMENT>$50K 69 NO ESCALATION | -63,930.06 |  |  |  |  | 100 |  |  |  |  |  |  |  |  |  |  |  |  |  |  |  |  |  |  |  |  |  |  |  |  |  |  |  |  | ADJ |  |  |  |  |  |  |  |  |  |  |  |  |  |
| 24364030 |  | Fab SHMS Gas Manifolds (CRYO SYS) Part A - Procurement |  | 38d | 2013-09-03 A | 2013-12-20 | 9-130M FS+228d | 88% | 34d | 2013-09-03 | 2013-10-24 | 288d | 6d | 8/5 M-F w/JLAB Holidays ReBaseline | PROCUREMENT<$50K 60 NO ESCALATION FY14; TRAVEL | 10,195.65 |  | 1223.478 | 8972.172 | 897217.2 | 100 |  | 3262.608 | FENKER H | 1 | 1 |  | U | HOWARD F |  |  |  | 09-012 | 09-022 |  | 10-069 |  | 11-026 | 11-046 | 12-012 | 12-036F | 13-006F |  |  |  |  |  |  | 08-016 |  |  | 24364030 | 5709.564 | EJ | 13-015 | PR | OB | EJ |  | EJ |  |  | 4 |
| 24364030a |  | Fab SHMS Gas Manifolds (CRYO SYS) Part A Labor FY13 |  | 20d | 2013-09-03 A | 2013-12-20 | 9-130M FS+228d | 88% | 34d | 2013-09-03 | 2013-09-30 | 354d | 66d | 8/5 M-F w/JLAB Holidays ReBaseline | MECH ENG [42.1 h]; MECH DES [42.1 h] | 5,139.76 | 2,919.31 |  |  |  |  |  | 1644.722352 | FENKER H | 1 | 1 |  | U | HOWARD F |  |  |  | 09-012 | 09-022 |  | 10-069 |  | 11-026 | 11-046 | 12-012 | 12-036F | 13-006F |  |  |  |  |  |  | 08-016 |  |  | 24364030 | 2878.264116 | EJ | 13-015 | PR |  | EJ |  | EJ |  |  | 4 |
| 24364030b |  | Fab SHMS Gas Manifolds (CRYO SYS) Part A Labor FY14 |  | 18d | 2013-09-03 A | 2013-12-20 | 24364030a FS-100d | 88% | 34d | 2013-10-01 | 2013-10-24 | 288d | 6d | 8/5 M-F w/JLAB Holidays ReBaseline | MECH ENG [37.9 h]; MECH DES [37.9 h] | 4,773.63 | 2,627.41 |  |  |  |  |  | 1527.562608 | FENKER H | 1 | 1 |  | U | HOWARD F |  |  |  | 09-012 | 09-022 |  | 10-069 |  | 11-026 | 11-046 | 12-012 | 12-036F | 13-006F |  |  |  |  |  |  | 08-016 |  |  | 24364030 | 2673.234564 | EJ | 13-015 | PR |  | EJ | 14-001 | EJ |  |  | 4 |
| 24364043 |  | Produce Drawings for Cryo System Connections & Controls FY13 |  | 43d | 2013-09-03 A | 2013-11-27 | 9-130M FS+228d | 40% | 19d | 2013-09-03 | 2013-10-31 | 283d | 1d | 8/5 M-F w/JLAB Holidays ReBaseline | MECH DES [24.8 h]; MECH ENG [24.8 h] | 3,079.07 | 2,135.48 |  |  |  |  |  | 0 | FENKER H | 1 | 1 |  | S | HOWARD F |  |  | ST |  |  |  |  |  |  |  |  |  | 13-006 |  |  |  |  |  |  |  |  |  | 24364043 | 1211.17854 |  | 13-015 | PR |  | EJ |  |  |  |  |  |
| 24364043a |  | Produce Drawings for Cryo System Connections & Controls FY14 |  | 18d | 2013-09-03 A | 2013-11-27 | 24364043 FS-100d | 40% | 19d | 2013-10-01 | 2013-10-24 | 308d | 70d | 8/5 M-F w/JLAB Holidays ReBaseline | MECH DES [28.53 h]; MECH ENG [28.53 h] | 3,593.93 | 2,456.67 |  |  |  |  |  | 0 | FENKER H | 1 | 1 |  | S | HOWARD F |  |  | ST |  |  |  |  |  |  |  |  |  | 13-006 |  |  |  |  |  |  |  |  |  | 24364043 | 1437.56964 |  | 13-015 | PR |  | EJ | 14-001 |  |  |  |  |
| 24364016 |  | Modify G0 Transfer Line |  | 107d | 2013-10-01 A | 2014-03-20 | 24368170 FS+5d | 18% | 89d | 2013-11-01 | 2014-04-15 | 238d | 0d | 8/5 M-F w/JLAB Holidays ReBaseline | MECH DES [656 h]; MECH ENG [48 h]; MECH TECH [2320 h] | 147,019.36 | 30,191.47 |  |  |  |  |  | 26463.4848 | FENKER H | 1 | 1 |  | S | HOWARD F |  |  | ST |  |  |  | 10-069 |  | 11-026 | 11-046 | 12-012 | 12-036F | 13-006 |  |  |  |  |  | 12-054 |  |  |  | 24364016 |  |  | 13-015 | PR |  | EJ | 14-001 |  |  |  | 4 |
| 24364065 |  | Proc Cables,panels & Pwr Supplies (CRYO SYS) |  | 38d | 2013-10-01 A | 2013-11-21 | 9-140M | 20% | 15d | 2013-11-01 | 2014-01-07 | 312d | 74d | 8/5 M-F w/JLAB Holidays ReBaseline | PROCUREMENT<$50K 60; MECH ENG [80 h]; MECH DES [80 h] | 22,934.71 | 6,099.6 | 10285.688 | 2571.422 | 257142.2 | 100 |  | 4586.942 | FENKER H | 1 | 1 |  | D | HOWARD F |  |  |  |  | 09-022 |  | 10-069 |  | 11-026 | 11-046 | 12-012 | 12-036F | 13-006F |  |  |  |  |  | 12-054 |  |  |  | 24364065 |  | CP | 13-015 | PR | OB-2 | EJ | 14-001 |  |  |  |  |
| 24364075 |  | Proc & Fab Various Connections etc (CRYO SYS) |  | 50d | 2013-10-01 A | 2014-01-16 | 24364030b FS-40d, 24364043 FS-20d, 24364030 FS-40d | 3% | 45d | 2014-01-02 | 2014-03-13 | 282d | 44d | 8/5 M-F w/JLAB Holidays ReBaseline | SUPPLIES & MATERIALS; MECH ENG [40 h]; PROCUREMENT>$50K 69 | 80,961.13 | 1,010.24 | 56928.0293 | 1760.6607 | 176066.07 | 100 |  | 2428.8339 | FENKER H | 1 | 1 |  | D | HOWARD F |  |  |  | 09-012 | 09-022 |  | 10-069 |  | 11-026 | 11-046 | 12-012 | 12-036F | 13-006F |  |  |  |  |  |  | 08-016 |  |  | 24364075 |  | EJ | 13-015 | PR | OB-2 | EJ | 14-001 | EJ |  | 12-022 |  |

Notes:
- 14363010: Steps: Draft Design Drawings Done (done); Draft CAD Models Done (done); Incorporate Boron Shielding in Design (done); Draft FEA Analysis (done); Commerical Components List (done); PDR - Final Design Outline (done); Structural Optimization Complete (done); FDR - Review of Draft Deliverables (done); CAD Drawings & 3D Model (done); Engineering Analysis Report (done); On-Site Assembly Plan (done); Final Design Report (done)
- 14363021: Steps: Utilities & Arrangements detector installation & access plans relay rack arrangement cableway & conduits (done); Doors, roof and wall panels & hardware doorways and doors removable wall blocks and roof blocks (done); Concrete & B4C pour (done); Oversight (done); Boron, lead panels (done)
- 14363021a: Steps: Utilities & Arrangements detector installation & access plans relay rack arrangement cableway & conduits (done); Doors, roof and wall panels & hardware doorways and doors removable wall blocks and roof blocks (done); Concrete & B4C pour (done); Oversight (done); Boron, lead panels (done)
- 14363030: Steps: Procure B4C (done); procure balance of painted lead bricks (done); paint lead bricks smelted from scrap (done); paint lead bricks from HKS (done); Procure plastic for concrete Part A (done); Procure plastic for concrete Part B (done)
- 14363030a: Steps: fabricate B4C cast panels (done); lead sheets (done); Aluminum sheets (done); Assembly (done)
- 14363021b: Explanation: 20 sheets in drawing
- 14364025: Steps: Engineering/Design Final Detail (done); PR/PR Prep (done); Bid Evaluation (done); Contract Oversight (done)
- 14364040: Steps: Final Drawings (done); Bid Evaluation (done); Fabrication (done)
- 14364030: Steps: Fab SHMS Gas Manifolds (CRYO SYS) (done)
- 14364043: Steps: Produce Drawings for Cryo System Connections & Controls (done)
- 24364043: Steps: Bend-test Anaconda under vacuum (done); Revise flex-line support drawings for final dimensions of Anaconda
- 24364043a: Steps: Bend-test Anaconda under vacuum (done); Revise flex-line support drawings for final dimensions of Anaconda
- 24364016: Steps: Assembly-welding of cryo gas lines; Leak-test vacuum vessel of Cryo Dist Xfer Line; Verify Cryo Dist Xfer Line instrumentation; Connect Cryo Dist Xfer Line for long-term pumpout; Install Cryo Distribution Transfer Line In Hall; Inspect, Pressure- & Leak-Check U-Tubes 1-10; Inspect, Pressure- & Leak-Check U-Tubes 11-20; Inspect, Pressure- & Leak-Check L-Tubes 1-10; Inspect, Pressure- & Leak-Check L-Tubes 11-15; Evacuate U-tubes prior to installation; N2 gas purge 20 U-Tubes & 15 L-Tubes; Weld & Leak-check Anaconda Vacuum Jacket (done); Leak & pressure-check anaconda extensions 1-2 (done); Leak & pressure-check anaconda extensions 3-4 (done); Leak & pressure-check anaconda extensions 5-6 (done); Install MLI, Weld Vac Jacket on Anaconda extensions 1-2; Install MLI, Weld Vac Jacket on Anaconda extensions 3-4; Install MLI, Weld Vac Jacket on Anaconda extensions 5-6; Final Leak & Pressure Test Anaconda; Pump to De-water Anaconda MLI

| ID | WBS | Activity | Duration | Start | Finish | Predecessors | Complete | Remaining | Planned start | Planned finish | Total float | Free float | Calendar | Resources | Cost | Actual cost | Calculated Remaining Total Cost | MONTHLY EV COST | RESP - Responsibility | STRT%COMP for CM EVM | FNSH%COMP for CM EVM | EVMS Reporting Codes | CAM RESPONSIBLE | CR 10-069 | CR 11-026 | CR 11-046 | CR 12-012 | CR 12-036 | CR 13-006 | Specification | Remaining Material Cost Based on % Compl | Claimed Material Cost Based on % Complet | Initial Claimed Material Calc | Claimed Material Divider | CR 09-022 | MARCH!!! | CR 08-016 | CR 09-012 | CR 12-054 | Activities with Steps | ReBaseline Actuals Adjustment | Original Activity ID Rebaseline | BOE Procurement | BOE Labor | CR 13-015 | Post Rebaseline | Obligated Prior to Rebaseline | CR 14-001 | PRIOR MONTH EV COST | BOE Expenses | CR 12-022 |
| --- | --- | --- | --- | --- | --- | --- | --- | --- | --- | --- | --- | --- | --- | --- | --- | --- | --- | --- | --- | --- | --- | --- | --- | --- | --- | --- | --- | --- | --- | --- | --- | --- | --- | --- | --- | --- | --- | --- | --- | --- | --- | --- | --- | --- | --- | --- | --- | --- | --- | --- | --- |
|  | 5 | **1.4.3.6.5 VACUUM SYSTEM** |  | 2009-07-01 | 2015-07-15 |  |  |  |  |  |  |  |  |  |  |  |  |  |  |  |  |  |  |  |  |  |  |  |  |  |  |  |  |  |  |  |  |  |  |  |  |  |  |  |  |  |  |  |  |  |  |
| 14365005 |  | Finalize Drawing for Comp Vac Sys | 60d | 2009-07-01 A | 2009-09-24 A | 12236020, 9-130M FS-960d | 100% |  |  |  |  |  |  | MECH ENG [40 h]; MECH DES [160 h] | 9,566.8 | 9,566.8 | 0 | 9566.8 | FENKER H | 1 | 1 | H | HOWARD F | 10-069 | 11-026 | 11-046 | 12-012 | 12-036F | 13-006F |  |  |  |  |  |  |  |  |  |  |  |  |  |  |  |  |  |  |  |  |  |  |
| 14365010 |  | Proc Turbo Pump systems | 62d | 2012-10-01 A | 2013-06-17 A | 9-130M, 14365005, 2-02M | 100% |  | 2012-10-01 | 2013-01-04 |  |  |  | MECH ENG [40 h]; PROCUREMENT<$50K 60; PROCUREMENT>$50K 69; MECH TECH [40 h] | 98,176.07 | 4,728.8 | 0 | 98176.07 | FENKER H | 1 | 1 | D | HOWARD F | 10-069 | 11-026 | 11-046 | 12-012 | 12-036F | 13-006F | 14365010 | 0 | 93447.27 | 9344727 | 100 | 09-022 | XX |  |  |  |  |  |  |  |  |  |  |  |  |  |  |  |
| 14365015 |  | Proc Roots Pump Sys | 62d | 2012-10-01 A | 2013-06-17 A | 9-130M, 2-02M, 14365005 | 100% |  | 2012-10-01 | 2013-01-04 |  |  |  | PROCUREMENT<$50K 60; MECH ENG [20 h] | 45,055.92 | 1,447.2 | 0 | 45055.92 | FENKER H | 1 | 1 | D | HOWARD F | 10-069 | 11-026 | 11-046 | 12-012 | 12-036F | 13-006F | 14365015 | 0 | 43608.72 | 4360872 | 100 | 09-022 | XX |  |  |  |  |  |  |  |  |  |  |  |  |  |  |  |
| 14365040 |  | Proc Shutter Exit Window | 130d | 2013-01-03 A | 2013-03-11 A | 9-120M FS+125d, 14365005, 9-130M FS+60d | 100% |  | 2013-02-01 | 2013-08-06 |  |  |  | PROCUREMENT<$50K 60 | 24,919.28 |  | 0 | 24919.28 | FENKER H | 1 | 1 | D | HOWARD F | 10-069 | 11-026 | 11-046 | 12-012 |  | 13-006F |  | 0 | 24919.28 | 2491928 | 100 | 09-022 |  | 08-016 | 09-012 | 12-054 |  |  |  |  |  |  |  |  |  |  |  |  |
| 14365023 |  | Manufacturing Drawings for Vacuum System Parts | 99d | 2013-05-03 A | 2013-08-30 A | 9-130M FS+59d | 100% |  | 2013-06-03 | 2013-10-21 |  |  |  | MECH DES [800 h] | 39,960.73 | 39,768 | 19884 | 39768 | FENKER H | 1 | 1 | S | HOWARD F |  |  |  |  |  | 13-006 |  |  |  |  |  |  |  |  |  |  | ST |  |  |  |  |  |  |  |  |  |  |  |
| 14365020 |  | Proc Valves & Plumbing | 60d | 2013-05-06 A | 2013-08-30 A | 9-130M FS+100d, 14365015 FS-20d, 14365010 FS-20d | 100% |  | 2013-06-28 | 2013-09-23 |  |  |  | MECH ENG [40 h]; PROCUREMENT>$50K 69 | 40,273.31 | 2,894.4 | 20136.655 | 40273.31 | FENKER H | 1 | 1 | D | HOWARD F | 10-069 | 11-026 | 11-046 | 12-012 | 12-036F | 13-006 | 14365020 | 0 | 37378.91 | 3737891 | 100 | 09-022 |  |  |  |  |  |  |  |  |  |  |  |  |  |  |  |  |
| 14365025 |  | Proc Gauges for Vac Sys | 60d | 2013-08-30 A | 2013-08-30 A | 14365010 FS-40d, 14365015 FS-40d, 2-02M, 9-130M | 100% |  | 2013-09-03 | 2013-11-25 |  |  |  | PROCUREMENT<$50K 60 | 24,919.28 |  | 24919.28 | 24919.28 | FENKER H | 1 | 1 | D | HOWARD F | 10-069 | 11-026 | 11-046 | 12-012 | 12-036F | 13-006 |  | 0 | 24919.28 | 2491928 | 100 | 09-022 |  |  |  |  |  |  |  |  |  |  |  |  |  |  |  |  |
| 14365035 |  | Proc Windows & Flanges | 70d | 2013-08-30 A | 2013-08-30 A | 9-130M FS+120d, 9-120M FS+125d, 14365005 | 100% |  | 2013-09-03 | 2013-12-11 |  |  |  | PROCUREMENT<$50K 60 | 37,378.91 |  | 37378.91 | 37378.91 | FENKER H | 1 | 1 | D | HOWARD F | 10-069 | 11-026 | 11-046 | 12-012 |  | 13-006F |  | 0 | 37378.91 | 3737891 | 100 | 09-022 |  | 08-016 | 09-012 | 12-054 |  |  |  |  |  |  |  |  |  |  |  |  |
| 14365055 |  | Re-Baseline Actuals Adjustment | 1d | 2013-08-30 A | 2013-08-30 A |  | 100% |  | 2013-09-03 | 2013-09-03 |  |  |  | PROCUREMENT>$50K 69 NO ESCALATION | -108,783.13 |  |  |  |  |  |  |  |  |  |  |  |  |  |  |  |  |  |  | 100 |  |  |  |  |  |  | ADJ |  |  |  |  |  |  |  |  |  |  |
| 24365020 |  | Proc Valves & Plumbing and Reliefs Part A | 62d | 2013-09-03 A | 2013-11-27 | 9-130M FS+228d |  | 19d |  |  | 358d |  | 8/5 M-F w/JLAB Holidays ReBaseline | MECH ENG; PROCUREMENT>$50K 69 NO ESCALATION FY14 | 20,707 |  |  | 0 | FENKER H | 1 | 1 | D | HOWARD F | 10-069 | 11-026 | 11-046 | 12-012 | 12-036F | 13-006 |  | 20707 | 0 | 0 | 100 | 09-022 |  |  |  |  |  |  | 24365020 | EJ | EJ | 13-015 | PR | OB |  |  |  |  |
| 24365020a |  | Proc Valves & Plumbing and Reliefs Part A Labor FY13 | 20d | 2013-09-03 A | 2014-01-08 | 9-130M FS+228d |  | 39d | 2013-09-03 | 2013-09-30 | 927d | 61d | 8/5 M-F w/JLAB Holidays ReBaseline | MECH ENG [6.45 h] | 466.72 | 248.92 |  | 0 | FENKER H | 1 | 1 | D | HOWARD F | 10-069 | 11-026 | 11-046 | 12-012 | 12-036F | 13-006 |  |  |  |  |  | 09-022 |  |  |  |  |  |  | 24365020 | EJ | EJ | 13-015 | PR |  |  |  |  |  |
| 24365020b |  | Proc Valves & Plumbing and Reliefs Part A Labor FY14 | 42d | 2013-09-03 A | 2014-01-08 | 24365020a FS-100d |  | 39d | 2013-10-01 | 2013-11-27 | 927d | 982d | 8/5 M-F w/JLAB Holidays ReBaseline | MECH ENG [13.55 h] | 1,011.78 | 522.93 |  | 0 | FENKER H | 1 | 1 | D | HOWARD F | 10-069 | 11-026 | 11-046 | 12-012 | 12-036F | 13-006 |  |  |  |  |  | 09-022 |  |  |  |  |  |  | 24365020 | EJ | EJ | 13-015 | PR |  | 14-001 |  |  |  |
| 24365023 |  | Manufacturing Drawings for Vacuum System Parts FY13 | 98d | 2013-09-03 A | 2014-01-31 | 9-130M FS+228d | 50% | 55d | 2013-10-01 | 2014-02-28 | 102d | 25d | 8/5 M-F w/JLAB Holidays ReBaseline | MECH DES [40.82 h] | 2,094.07 | 905.58 |  | 0 | FENKER H | 1 | 1 | H | HOWARD F |  |  |  |  |  | 13-006 |  |  |  |  |  |  |  |  |  |  |  |  | 24365023 |  | EJ | 13-015 | PR |  |  | 1014.5811 |  |  |
| 24365023a |  | Manufacturing Drawings for Vacuum System Parts FY14 | 78d | 2013-09-03 A | 2014-01-31 | 24365023 FS-100d | 50% | 55d | 2013-10-01 | 2014-01-31 | 102d | 25d | 8/5 M-F w/JLAB Holidays ReBaseline | MECH DES [159.18 h] | 8,165.93 | 3,531.36 |  | 0 | FENKER H | 1 | 1 | H | HOWARD F |  |  |  |  |  | 13-006 |  |  |  |  |  |  |  |  |  |  |  |  | 24365023 |  | EJ | 13-015 | PR |  | 14-001 | 4082.967 |  |  |
| 24365025 |  | Proc Valves & Plumbing and Reliefs Part B | 267d | 2013-09-03 A | 2014-09-30 | 9-130M FS+228d |  | 224d | 2013-10-22 | 2014-11-18 | 153d |  | 8/5 M-F w/JLAB Holidays ReBaseline | PROCUREMENT<$50K 60 | 88,724.36 |  |  | 0 | FENKER H | 1 | 1 | D | HOWARD F | 10-069 | 11-026 | 11-046 | 12-012 | 12-036F | 13-006 |  | 88724.36 | 0 | 0 | 100 | 09-022 |  |  |  |  |  |  | 24365025 | OB |  | 13-015 | PR | OB-2 |  |  |  |  |
| 24365030 |  | Proc Spool & Bellows for All Magnets Part A | 203d | 2013-09-03 A | 2014-06-30 | 24365023 FS-100d, 9-130M FS+228d | 38% | 160d |  |  | 198d | 43d | 8/5 M-F w/JLAB Holidays ReBaseline | PROCUREMENT>$50K 69 NO ESCALATION FY14 | 14,446.86 |  |  | 0 | FENKER H | 1 | 1 | D | HOWARD F | 10-069 | 11-026 | 11-046 | 12-012 |  | 13-006 |  | 8957.0532 | 5489.8068 | 548980.68 | 100 | 09-022 |  |  |  | 12-054 |  |  | 24365030 | EJ | EJ | 13-015 | PR | OB |  | 5489.8068 | EJ |  |
| 24365035 |  | Proc Windows & Flanges Part A | 98d | 2013-09-03 A | 2014-01-31 | 9-130M FS+228d | 12% | 55d |  |  | 243d | 43d | 8/5 M-F w/JLAB Holidays ReBaseline | PROCUREMENT<$50K 60 | 18,066 |  |  | 2167.92 | FENKER H | 1 | 1 | D | HOWARD F | 10-069 | 11-026 | 11-046 | 12-012 |  |  |  | 15898.08 | 2167.92 | 216792 | 100 | 09-022 |  | 08-016 | 09-012 | 12-054 |  |  | 24365035 | EJ | EJ | 13-015 | PR | OB |  |  |  |  |
| 24365045 |  | Proc Sieve Slit Sys Part A | 192d | 2013-09-03 A | 2014-06-13 | 24365030 FS-203d, 24365032 FS-390d, 24365040 FS-140d, 24365035 FS-98d | 4% | 149d |  |  | 344d |  | 8/5 M-F w/JLAB Holidays ReBaseline | PROCUREMENT<$50K 60 NO ESCALATION FY15; PROCUREMENT>$50K 69 NO ESCALATION FY15 | 29,198 |  |  | 1167.92 | FENKER H | 1 | 1 | D | HOWARD F | 10-069 | 11-026 | 11-046 | 12-012 |  | 13-006 |  | 28030.08 | 1167.92 | 116792 | 100 | 09-022 |  | 08-016 | 09-012 | 12-054 |  |  | 24365045 | PE | PE | 13-015 | PR | OB |  |  |  |  |
| 24365032 |  | Proc Spool & Bellows for All Magnets Part B | 203d | 2013-10-07 A | 2014-12-22 | 9-130M FS+228d, 24365023 FS-80d, 24365023a FS-80d | 33% | 281d | 2013-12-13 | 2014-10-09 | 77d | 0d | 8/5 M-F w/JLAB Holidays ReBaseline | PROCUREMENT>$50K 69 | 20,638 |  |  | 6810.54 | FENKER H | 1 | 1 | D | HOWARD F | 10-069 | 11-026 | 11-046 | 12-012 |  | 13-006 |  | 13827.46 | 6810.54 | 681054 | 100 | 09-022 |  |  |  | 12-054 |  |  | 24365030 | EJ | EJ | 13-015 | PR | OB-2 | 14-001 |  | EJ |  |
| 24365040 |  | Proc Windows & Flanges Part B | 75d | 2013-12-04 | 2014-03-31 | 9-140M FS+44d |  |  |  |  | 202d | 44d | 8/5 M-F w/JLAB Holidays ReBaseline | PROCUREMENT<$50K 60 | 19,928.99 |  |  | 0 | FENKER H | 1 | 1 | D | HOWARD F | 10-069 | 11-026 | 11-046 | 12-012 |  |  |  | 19928.99 | 0 | 0 | 100 | 09-022 |  | 08-016 | 09-012 | 12-054 |  |  | 24365035 | EJ | EJ | 13-015 | PR |  | 14-001 |  |  |  |
| 24365047 |  | Proc Sieve Slit Sys Part B | 192d | 2014-09-26 | 2015-07-10 | 24365032 FS-60d, 24365040, 24365035, 24365030 FS-60d |  |  |  |  | 80d |  | 8/5 M-F w/JLAB Holidays ReBaseline | PROCUREMENT<$50K 60 NO ESCALATION FY15; PROCUREMENT>$50K 69 NO ESCALATION FY15 | 65,112.86 |  |  | 0 | FENKER H | 1 | 1 | D | HOWARD F | 10-069 | 11-026 | 11-046 | 12-012 |  | 13-006 |  | 65112.86 | 0 | 0 | 100 | 09-022 |  | 08-016 | 09-012 | 12-054 |  |  | 24365045 | PE | PE | 13-015 | PR |  | 14-001 |  |  |  |
| 24365050 |  | Fab Slit Controls | 195d | 2014-09-26 | 2015-07-15 | 24365040, 24365030 FS-60d, 24365035, 24365032 FS-60d |  |  |  |  | 77d |  | 8/5 M-F w/JLAB Holidays ReBaseline | PROCUREMENT<$50K 60 NO ESCALATION FY15; MECH ENG [80 h] | 18,445.79 |  |  | 0 | FENKER H | 1 | 1 | S | HOWARD F | 10-069 | 11-026 | 11-046 | 12-012 |  | 13-006 |  | 12472.19 | 0 | 0 | 100 | 09-022 |  | 08-016 | 09-012 | 12-054 | ST |  | 24365050 | PE | PE | 13-015 | PR |  | 14-001 |  |  |  |
|  | 6 | **1.4.3.6.6 CABLING** |  | 2012-02-01 | 2014-07-24 |  |  |  |  |  |  |  |  |  |  |  |  |  |  |  |  |  |  |  |  |  |  |  |  |  |  |  |  |  |  |  |  |  |  |  |  |  |  |  |  |  |  |  |  |  |  |
| 14366005 |  | Proc HV Cables (CABLING) Original | 4d | 2012-02-01 A | 2012-02-06 A | 9-120M FS+60d | 100% |  |  |  |  |  |  | ELEC ENG [2.77 h] | 195.45 | 195.45 | 0 | 195.4512 | FENKER H | 1 | 1 | H | HOWARD F | 10-069 | 11-026 | 11-046 |  |  |  |  |  |  |  |  |  |  |  |  |  |  |  |  |  |  |  |  |  |  |  |  | 12-022 |
| 14366010 |  | Proc LV & Signal Cables (CABLING) Original | 4d | 2012-02-01 A | 2012-02-06 A | 9-120M FS+60d | 100% |  |  |  |  |  |  | ELEC ENG [2.77 h] | 195.45 | 195.45 | 0 | 195.4512 | FENKER H | 1 | 1 | H | HOWARD F | 10-069 | 11-026 | 11-046 |  |  |  |  |  |  |  |  |  |  |  |  |  |  |  |  |  |  |  |  |  |  |  |  | 12-022 |
| 14366020 |  | Reverse Entry Per CR12-022 | 4d | 2012-02-01 A | 2012-02-06 A | 9-120M FS+80d | 100% |  |  |  |  |  |  | ELEC ENG [-5.54 h] | -390.9 | -390.9 |  |  | FENKER H | 1 | 1 | H | HOWARD F | 10-069 | 11-026 | 11-046 |  |  |  |  |  |  |  |  |  |  |  |  |  |  |  |  |  |  |  |  |  |  |  |  | 12-022 |
| 14366007 |  | Proc HV Cables (CABLING) Revised per CR12-022 | 130d | 2012-12-03 A | 2012-12-17 A | 9-130M | 100% |  | 2013-01-02 | 2013-07-08 |  |  |  | ELEC ENG [20 h]; PROCUREMENT<$50K 60 | 43,712.72 | 1,456.2 | 0 | 43712.72 | FENKER H | 1 | 1 | H | HOWARD F | 10-069 | 11-026 | 11-046 |  |  |  | 14366007 | 0 | 42256.52 | 4225652 | 100 |  |  |  |  |  |  |  |  |  |  |  |  |  |  |  |  | 12-022 |
| 14366015 |  | Proc LV & Signal Cables (CABLING) Revised per CR12-022 | 130d | 2012-12-03 A | 2012-12-17 A | 9-130M | 100% |  | 2013-01-02 | 2013-07-08 |  |  |  | ELEC ENG [20 h]; PROCUREMENT<$50K 60 | 19,566.14 | 1,456.2 | 0 | 19566.14 | FENKER H | 1 | 1 | H | HOWARD F | 10-069 | 11-026 | 11-046 |  |  | 13-006F | 14366015 | 0 | 18109.94 | 1810994 | 100 |  |  |  |  |  |  |  |  |  |  |  |  |  |  |  |  | 12-022 |
| 14366025 |  | Terminate Cables | 127d | 2013-08-30 A | 2013-08-30 A | 9-140M FS+80d, 14366015 FS+55d | 100% |  | 2014-02-03 | 2014-08-01 |  |  |  | ELEC TECH [112.79 h] | 5,300 | 5,136.46 | 14572.8 | 5136.4566 | FENKER H | 1 | 1 | H | HOWARD F |  |  |  |  |  | 13-006 |  |  |  |  |  |  |  |  |  |  |  |  |  |  |  |  |  |  |  |  |  |  |
| 14366030 |  | Re-Baseline Actuals Adjustment | 1d | 2013-08-30 A | 2013-08-30 A |  | 100% |  | 2013-09-03 | 2013-09-03 |  |  |  | PROCUREMENT>$50K 69 NO ESCALATION | -61,653.78 |  |  |  |  |  |  |  |  |  |  |  |  |  |  |  |  |  |  | 100 |  |  |  |  |  |  | ADJ |  |  |  |  |  |  |  |  |  |  |
| 24366025 |  | Terminate Cables | 122d | 2014-02-03 | 2014-07-24 | 9-140M FS+80d |  |  |  |  | 227d | 24d | 8/5 M-F w/JLAB Holidays ReBaseline | ELEC TECH [320 h] | 15,036.8 |  |  | 0 | FENKER H | 1 | 1 | U | HOWARD F |  |  |  |  |  | 13-006 |  |  |  |  |  |  |  |  |  |  |  |  | 24366025 |  | PE | 13-015 | PR |  | 14-001 |  |  |  |

Notes:
- 14365005: Explanation: Reduced Lag on All activities from 169.8 to 160 weeks
- 14365023: Steps: Spools & Bellows HB and Q1 (done); Spools & Bellows Q2, Q3, D (done); Spools & Bellows after Dipole (done); Upstream Sieve (done); HB-Q1 Sieve (done); Downstream Window (done); Shutter (done); Instrumentation Connections (done)
- 24365050: Steps: Motors, Controllers, Wiring, Connectors spec'd. PR's submitted; 50% Procurements delivered; 100% Procurements delivered; System assembled on bench; controls programming started.; System programmed & Tested. Read to install.
- 14366020: Explanation: "S" History change per CR12-022
- 14366007: Explanation: "S" History change per CR12-022
- 14366015: Explanation: "S" History change per CR12-022
- 14366025: Explanation: "S" History change per CR12-022
- 24366025: Explanation: "S" History change per CR12-022

| ID | WBS | Activity | Type | Duration | Start | Finish | Predecessors | Complete | Remaining | Planned start | Planned finish | Total float | Free float | Constraint | Calendar | Resources | Cost | Actual cost | Calculated Remaining Total Cost | MONTHLY EV COST | RESP - Responsibility | STRT%COMP for CM EVM | FNSH%COMP for CM EVM | EVMS Reporting Codes | CAM RESPONSIBLE | CR 10-069 | CR 11-026 | CR 11-046 | CR 12-012 | CR 12-036 | CR 13-006 | Claimed Material Divider | ReBaseline Actuals Adjustment | CR 09-022 | CR 10-030 | Milestone Level | Specification | Remaining Material Cost Based on % Compl | Claimed Material Cost Based on % Complet | Initial Claimed Material Calc | CR 11-025 | MARCH!!! | CR 12-054 | CR 10-076 | Advance Purchase Plan > 500K | CR 08-052 | Pat's Code | CR 12-003 | Activities with Steps | CR 08-016 | CR 09-012 | LOE % Pre Calc | LOE % | LOE Divider | LOE Multiplier | CR 12-022 | Original Activity ID Rebaseline | Howard's Code | BOE Procurement | CR 13-015 | Post Rebaseline | Obligated Prior to Rebaseline | PRIOR MONTH EV COST | BOE Labor | BOE Expenses | CR 14-001 |
| --- | --- | --- | --- | --- | --- | --- | --- | --- | --- | --- | --- | --- | --- | --- | --- | --- | --- | --- | --- | --- | --- | --- | --- | --- | --- | --- | --- | --- | --- | --- | --- | --- | --- | --- | --- | --- | --- | --- | --- | --- | --- | --- | --- | --- | --- | --- | --- | --- | --- | --- | --- | --- | --- | --- | --- | --- | --- | --- | --- | --- | --- | --- | --- | --- | --- | --- |
|  | 7 | **1.4.3.6.7 SOS PIVOT MODIFICATION** |  |  | 2011-11-01 | 2013-08-30 |  |  |  |  |  |  |  |  |  |  |  |  |  |  |  |  |  |  |  |  |  |  |  |  |  |  |  |  |  |  |  |  |  |  |  |  |  |  |  |  |  |  |  |  |  |  |  |  |  |  |  |  |  |  |  |  |  |  |  |  |
| 14367005 |  | Proc Parts for SHMS Pivot Connection (SOS PIVOT MOD) |  | 20d | 2011-11-01 A | 2011-11-30 A | 2-02M FS-130d, 9-120M FS+22d | 100% |  |  |  |  |  |  |  | MECH DES [40 h]; MECH ENG [40 h] | 4,731.6 | 4,731.6 | 0 | 4731.6 | FENKER H | 1 | 1 | H | HOWARD F | 10-069 | 11-026 | 11-046 | 12-012 | 12-036F | 13-006F |  |  |  |  |  |  |  |  |  |  |  |  |  |  |  |  |  |  |  |  |  |  |  |  |  |  |  |  |  |  |  |  |  |  |  |
| 14367010 |  | Re-Baseline Actuals Adjustment |  | 1d | 2013-08-30 A | 2013-08-30 A |  | 100% |  | 2013-09-03 | 2013-09-03 |  |  |  |  | PROCUREMENT>$50K 69 NO ESCALATION | -4,731.59 |  |  |  |  |  |  |  |  |  |  |  |  |  |  | 100 | ADJ |  |  |  |  |  |  |  |  |  |  |  |  |  |  |  |  |  |  |  |  |  |  |  |  |  |  |  |  |  |  |  |  |  |
|  | 8 | **1.4.3.6.8 INSTALLATION** |  |  | 2011-05-13 | 2015-12-23 |  |  |  |  |  |  |  |  |  |  |  |  |  |  |  |  |  |  |  |  |  |  |  |  |  |  |  |  |  |  |  |  |  |  |  |  |  |  |  |  |  |  |  |  |  |  |  |  |  |  |  |  |  |  |  |  |  |  |  |  |
| 14368171 |  | Strip Clean The SOS: Hoses, Cable & Shielding |  | 109d | 2011-05-13 A | 2011-10-17 A | 4A-01M | 100% |  |  |  |  |  |  |  |  |  |  |  | 0 | FENKER H | 1 | 1 | Z | HOWARD F |  |  |  |  |  |  |  |  | 09-022 | 10-030 |  |  |  |  |  |  |  |  |  |  |  |  |  |  |  |  |  |  |  |  |  |  |  |  |  |  |  |  |  |  |  |
| 14368170 |  | Remove Remaining HKS/HES Components |  | 37d | 2011-09-01 A | 2011-10-24 A | 4A-01M FS+60d | 100% |  |  |  |  |  |  |  |  |  |  |  | 0 | FENKER H | 1 | 1 | Z | HOWARD F |  |  |  |  |  |  |  |  | 09-022 | 10-030 |  |  |  |  |  |  |  |  |  |  |  |  |  |  |  |  |  |  |  |  |  |  |  |  |  |  |  |  |  |  |  |
| 14368005 |  | Prep for Safty Review for Installtn Plans (Installtn) |  | 54d | 2012-01-31 A | 2012-04-16 A | 9-120M FS+60d | 100% |  |  |  |  |  |  |  | MECH DES [320 h]; MECH ENG [160 h]; ELEC ENG [160 h] | 37,923.2 | 37,923.2 | 0 | 37923.2 | FENKER H | 1 | 1 | H | HOWARD F |  |  | 11-046 |  |  |  |  |  | 09-022 |  |  |  |  |  |  |  |  |  |  |  |  |  |  |  |  |  |  |  |  |  |  |  |  |  |  |  |  |  |  |  |  |
| 14368010M |  | Comp Sfty Review for Installtn Plans (Installtn) | milestone | 0d | 2012-04-16 A | 2012-04-16 A | 14368005 FS+20d | 100% |  | 2012-05-14 | 2012-05-14 |  |  |  |  |  |  |  |  | 0 | FENKER H | 1 | 1 | M | HOWARD F |  |  | 11-046 |  |  |  |  |  |  |  | 6 |  |  |  |  |  |  |  |  |  |  |  |  |  |  |  |  |  |  |  |  |  |  |  |  |  |  |  |  |  |  |
| 14368176 |  | Reroute HMS Cableways to Clear SHMS |  | 176d | 2012-05-01 A | 2013-06-17 A | 2-02M, 2-07M FS-40d | 100% |  | 2012-05-01 | 2013-01-16 |  |  |  |  | PROCUREMENT<$50K 60; MECH DES [80 h]; MECH TECH [80 h] | 18,151.16 | 7,556.28 | 0 | 18056.98 | FENKER H | 1 | 1 | H | HOWARD F | 10-069 | 11-026 | 11-046 | 12-012 | 12-036F | 13-006F | 100 |  | 09-022 |  |  | 14368176 | 0 | 10648.18 | 1064818 | 11-025 | XX |  |  |  |  |  |  |  |  |  |  |  |  |  |  |  |  |  |  |  |  |  |  |  |  |
| 14368172 |  | Radiation Cooldown |  | 39d | 2012-05-18 A | 2012-07-13 A | 2-02M | 100% |  |  |  |  |  |  |  |  |  |  |  | 0 | FENKER H | 1 | 1 | Z | HOWARD F | 10-069 | 11-026 | 11-046 | 12-012 | 12-036F | 13-006F |  |  | 09-022 |  |  |  |  |  |  | 11-025 |  | 12-054F |  |  |  |  |  |  |  |  |  |  |  |  |  |  |  |  |  |  |  |  |  |  |  |
| 14368172a |  | Qweak Post Run Alignment Survey |  | 39d | 2012-05-18 A | 2012-07-13 A | 2-02M, 14368172 FS-10d | 100% |  |  |  |  |  |  |  |  |  |  |  | 0 | FENKER H | 1 | 1 | Z | HOWARD F | 10-069 | 11-026 | 11-046 | 12-012 | 12-036F | 13-006F |  |  | 09-022 |  |  |  |  |  |  | 11-025 |  | 12-054F |  |  |  |  |  |  |  |  |  |  |  |  |  |  |  |  |  |  |  |  |  |  |  |
| 14368174 |  | Dismantle & Remove Qweak Electronics Bunker |  | 10d | 2012-06-05 A | 2012-06-18 A | 14368172a FS-20d, 14368172 FS-20d | 100% |  |  |  |  |  |  |  |  |  |  |  | 0 | FENKER H | 1 | 1 | Z | HOWARD F | 10-069 | 11-026 | 11-046 | 12-012 | 12-036F | 13-006F |  |  | 09-022 |  |  |  |  |  |  | 11-025 |  | 12-054F |  |  |  |  |  |  |  |  |  |  |  |  |  |  |  |  |  |  |  |  |  |  |  |
| 14368174h |  | Remove HKS Dummy weight |  | 1d | 2012-06-16 A | 2012-06-18 A | 14368174 | 100% |  | 2012-06-18 | 2012-06-18 |  |  |  |  |  |  |  |  | 0 | FENKER H | 1 | 1 | Z | HOWARD F | 10-069 |  | 11-046 | 12-012 | 12-036F | 13-006F |  |  | 09-022 |  |  |  |  |  |  | 11-025 |  | 12-054F |  |  |  |  |  |  |  |  |  |  |  |  |  |  |  |  |  |  |  |  |  |  |  |
| 14368174j |  | Remove Qweak cableling and trays |  | 41d | 2012-06-18 A | 2012-08-13 A | 14368174h FS-20d | 100% |  |  |  |  |  |  |  |  |  |  |  | 0 | FENKER H | 1 | 1 | Z | HOWARD F | 10-069 |  | 11-046 | 12-012 | 12-036F | 13-006F |  |  | 09-022 |  |  |  |  |  |  | 11-025 |  | 12-054F |  |  |  |  |  |  |  |  |  |  |  |  |  |  |  |  |  |  |  |  |  |  |  |
| 14368174k |  | Remove Qweak Region 3 Shield Hut |  | 46d | 2012-06-18 A | 2012-08-20 A | 14368174j FS-25d | 100% |  |  |  |  |  |  |  |  |  |  |  | 0 | FENKER H | 1 | 1 | Z | HOWARD F | 10-069 |  | 11-046 | 12-012 | 12-036F | 13-006F |  |  | 09-022 |  |  |  |  |  |  | 11-025 |  | 12-054F |  |  |  |  |  |  |  |  |  |  |  |  |  |  |  |  |  |  |  |  |  |  |  |
| 14368174n |  | Remove Qweak Region 3 Detectors and support structures |  | 46d | 2012-06-18 A | 2012-08-20 A | 14368174k FS-20d | 100% |  |  |  |  |  |  |  |  |  |  |  | 0 | FENKER H | 1 | 1 | Z | HOWARD F | 10-069 |  | 11-046 | 12-012 | 12-036F | 13-006F |  |  | 09-022 |  |  |  |  |  |  | 11-025 |  | 12-054F |  |  |  |  |  |  |  |  |  |  |  |  |  |  |  |  |  |  |  |  |  |  |  |
| 14368174s |  | Remove Qweak cryo target complete |  | 60d | 2012-06-18 A | 2012-09-10 A | 14368174r FS-60d | 100% |  |  |  |  |  |  |  |  |  |  |  | 0 | FENKER H | 1 | 1 | Z | HOWARD F | 10-069 |  | 11-046 | 12-012 | 12-036F | 13-006F |  |  | 09-022 |  |  | 14368174s |  |  |  | 11-025 |  | 12-054F |  |  |  |  |  |  |  |  |  |  |  |  |  |  |  |  |  |  |  |  |  |  |  |
| 14368174t |  | Remove all remaining 9.5" concrete pads |  | 132d | 2012-06-18 A | 2012-12-17 A | 14368174s FS-60d | 100% |  | 2012-06-18 | 2012-12-21 |  |  |  |  |  |  |  |  | 0 | FENKER H | 1 | 1 | Z | HOWARD F | 10-069 |  | 11-046 | 12-012 | 12-036F | 13-006F |  |  | 09-022 |  |  | 14368174t |  |  |  | 11-025 |  | 12-054F |  |  |  |  |  |  |  |  |  |  |  |  |  |  |  |  |  |  |  |  |  |  |  |
| 14368173 |  | Disconnect & Remove Qweak Girder |  | 12d | 2012-07-15 A | 2012-07-31 A | 3P-04M, 14368172 | 100% |  | 2012-07-16 | 2012-07-31 |  |  |  |  |  |  |  |  | 0 | FENKER H | 1 | 1 | Z | HOWARD F | 10-069 | 11-026 | 11-046 | 12-012 | 12-036F | 13-006F |  |  | 09-022 |  |  |  |  |  |  |  |  |  | 10-076 |  |  |  |  |  |  |  |  |  |  |  |  |  |  |  |  |  |  |  |  |  |  |
| 14368174p |  | Remove QTOR Magnet |  | 10d | 2012-08-06 A | 2012-08-19 A | 14368174n | 100% |  | 2012-08-06 | 2012-08-17 |  |  |  |  |  |  |  |  | 0 | FENKER H | 1 | 1 | Z | HOWARD F | 10-069 |  | 11-046 | 12-012 | 12-036F | 13-006F |  |  | 09-022 |  |  |  |  |  |  | 11-025 |  | 12-054F |  |  |  |  |  |  |  |  |  |  |  |  |  |  |  |  |  |  |  |  |  |  |  |
| 14368174q |  | Remove Qweak shield wall and beam dump sections |  | 11d | 2012-08-06 A | 2012-08-20 A | 14368174p | 100% |  |  |  |  |  |  |  |  |  |  |  | 0 | FENKER H | 1 | 1 | Z | HOWARD F | 10-069 |  | 11-046 | 12-012 | 12-036F | 13-006F |  |  | 09-022 |  |  |  |  |  |  | 11-025 |  | 12-054F |  |  |  |  |  |  |  |  |  |  |  |  |  |  |  |  |  |  |  |  |  |  |  |
| 14368174r |  | Remove Qweak regions 1 and 2 |  | 6d | 2012-08-20 A | 2012-08-27 A | 14368174q | 100% |  |  |  |  |  |  |  |  |  |  |  | 0 | FENKER H | 1 | 1 | Z | HOWARD F | 10-069 |  | 11-046 | 12-012 | 12-036F | 13-006F |  |  | 09-022 |  |  |  |  |  |  | 11-025 |  | 12-054F |  |  |  |  |  |  |  |  |  |  |  |  |  |  |  |  |  |  |  |  |  |  |  |
| 14368174a |  | Install SOS Rails, Move SOS and Remove doors and door frame |  | 8d | 2012-11-03 A | 2012-11-14 A | 14368174 FS+59d | 100% |  | 2012-11-05 | 2012-11-14 |  |  |  |  |  |  |  |  | 0 | FENKER H | 1 | 1 | Z | HOWARD F | 10-069 |  | 11-046 | 12-012 | 12-036F | 13-006F |  |  | 09-022 |  |  | 14368174a |  |  |  | 11-025 |  |  |  |  |  |  |  |  |  |  |  |  |  |  |  |  |  |  |  |  |  |  |  |  |  |
| 14368174d |  | Remove SOS Dipole |  | 6d | 2012-11-12 A | 2012-11-19 A | 14368174c, 14368174s | 100% |  |  |  |  |  |  |  |  |  |  |  | 0 | FENKER H | 1 | 1 | Z | HOWARD F | 10-069 |  | 11-046 | 12-012 | 12-036F | 13-006F |  |  | 09-022 |  |  | 14368174d |  |  |  | 11-025 |  |  |  |  |  |  |  |  |  |  |  |  |  |  |  |  |  |  |  |  |  |  |  |  |  |
| 14368174b |  | Remove SOS Hydraulic Cylinders and supports |  | 4d | 2012-11-17 A | 2012-11-26 A | 14368174a | 100% |  | 2012-11-19 | 2012-11-26 |  |  |  |  |  |  |  |  | 0 | FENKER H | 1 | 1 | Z | HOWARD F | 10-069 |  | 11-046 | 12-012 | 12-036F | 13-006F |  |  | 09-022 |  |  | 14368174b |  |  |  | 11-025 |  |  |  |  |  |  |  |  |  |  |  |  |  |  |  |  |  |  |  |  |  |  |  |  |  |
| 14368174c |  | Move SOS Back and Saw cut and remove concrete |  | 15d | 2012-12-03 A | 2012-12-17 A | 14368174b | 100% |  | 2013-01-02 | 2013-01-23 |  |  |  |  |  |  |  |  | 0 | FENKER H | 1 | 1 | Z | HOWARD F | 10-069 |  | 11-046 | 12-012 | 12-036F | 13-006F |  |  | 09-022 |  |  | 14368174c |  |  |  | 11-025 |  |  |  |  |  |  |  |  |  |  |  |  |  |  |  |  |  |  |  |  |  |  |  |  |  |
| 14368174f |  | Saw cut and remove remaining SOS concrete |  | 3d | 2013-01-07 A | 2013-02-11 A | 14368174d FS+40d | 100% |  | 2013-02-01 | 2013-02-05 |  |  |  |  |  |  |  |  | 0 | FENKER H | 1 | 1 | Z | HOWARD F | 10-069 |  | 11-046 | 12-012 | 12-036F | 13-006 |  |  | 09-022 |  |  | 14368174f |  |  |  | 11-025 | XX |  |  |  |  |  |  |  |  |  |  |  |  |  |  |  |  |  |  |  |  |  |  |  |  |
| 14368322 |  | Re-Establish Hall-C Alignment Network Prior to SHMS Assy |  | 5d | 2013-01-14 A | 2013-01-31 A | 14368174t FS+54d | 100% |  | 2013-03-14 | 2013-03-20 |  |  |  |  | MECH TECH [80 h] | 3,668.8 | 3,668.8 | 0 | 3668.8 | FENKER H | 1 | 1 | H | HOWARD F |  |  |  |  |  | 13-006 |  |  |  |  |  |  |  |  |  |  |  |  |  | APP |  |  |  |  |  |  |  |  |  |  |  |  |  |  |  |  |  |  |  |  |  |
| 14368325 |  | Install Rails of Supprt Struct |  | 31d | 2013-01-14 A | 2013-02-11 A | 14368174t FS+5d, 14362015, 14368322 FS-40d | 100% |  | 2013-02-01 | 2013-03-18 |  |  |  |  | SUPPLIES & MATERIALS; MSHOP; PLABOR; MECH TECH [80 h] | 44,790.42 | 3,668.8 | 0 | 44790.42 | FENKER H | 1 | 1 | H | HOWARD F | 10-069 |  | 11-046 | 12-012 | 12-036F | 13-006F |  |  | 09-022 |  |  | 14368325 |  |  |  |  |  | 12-054 |  |  | 08-052 |  |  |  |  |  |  |  |  |  |  |  |  |  |  |  |  |  |  |  |  |
| 14368174g |  | Remove SOS Chassis , rails and pivot bearing |  | 17d | 2013-02-06 A | 2013-02-11 A | 14368174f | 100% |  | 2013-03-06 | 2013-03-28 |  |  |  |  |  |  |  |  | 0 | FENKER H | 1 | 1 | Z | HOWARD F | 10-069 |  | 11-046 | 12-012 | 12-036F | 13-006 |  |  | 09-022 |  |  | 14368174g |  |  |  | 11-025 | XX |  |  |  |  |  |  |  |  |  |  |  |  |  |  |  |  |  |  |  |  |  |  |  |  |
| 14368180 |  | Restore HaLL C and ESR Cryo To Base Config. |  | 10d | 2013-02-18 A | 2013-06-17 A | 2-02M, 9-130M | 100% |  | 2013-03-18 | 2013-03-29 |  |  |  |  |  |  |  |  | 0 | FENKER H | 1 | 1 | Z | HOWARD F | 10-069 | 11-026 | 11-046 | 12-012 | 12-036F |  |  |  | 09-022 |  |  | 14368180 |  |  |  |  | XX |  |  |  |  | Pat | 12-003 |  |  |  |  |  |  |  |  |  |  |  |  |  |  |  |  |  |  |
| 14368175 |  | Ccan and platform removal |  | 84d | 2013-03-04 A | 2013-08-30 A | 14368020 FS-100d | 100% |  | 2013-04-01 | 2013-07-29 |  |  |  |  | MECH TECH [880 h]; MECH DES [240 h] | 52,287.2 | 52,287.2 | 10457.44 | 52287.2 | FENKER H | 1 | 1 | S | HOWARD F | 10-069 | 11-026 | 11-046 | 12-012 | 12-036F | 13-006 |  |  | 09-022 |  |  | 14368175 |  |  |  | 11-025 |  | 12-054 |  |  |  |  |  | ST |  |  |  |  |  |  |  |  |  |  |  |  |  |  |  |  |  |
| 14368207 |  | Complete Readiness Review for SHMS DCPS Testing |  | 11d | 2013-03-11 A | 2013-08-30 A | 9-130M FS+59d | 100% |  | 2013-04-01 | 2013-04-15 |  |  |  |  | MECH ENG [40 h]; MECH DES [40 h]; SCIENTIST [40 h] | 7,797.2 | 7,797.2 | 3898.6 | 7797.2 | FENKER H | 1 | 1 | H | HOWARD F |  |  |  |  |  | 13-006 |  |  |  |  |  |  |  |  |  |  | XX |  |  |  |  |  |  |  |  |  |  |  |  |  |  |  |  |  |  |  |  |  |  |  |  |
| 14368327 |  | Check Rail Alignment |  | 1d | 2013-03-11 A | 2013-03-11 A | 14368325 FS+27d | 100% |  | 2013-04-01 | 2013-04-01 |  |  |  |  | MECH TECH [16 h] | 733.76 |  | 0 | 733.76 | FENKER H | 1 | 1 | H | HOWARD F |  |  |  |  |  | 13-006 |  |  |  |  |  |  |  |  |  |  |  |  |  |  |  |  |  |  |  |  |  |  |  |  |  |  |  |  |  |  |  |  |  |  |  |
| 14368335M |  | Central Rails for SHMS Installed (SHIELD HOUSE) | milestone | 0d | 2013-03-11 A | 2013-03-11 A | 14368325, 14368327 | 100% |  | 2013-04-02 | 2013-04-02 |  |  |  |  |  |  |  |  | 0 | FENKER H | 1 | 1 | M | HOWARD F | 10-069 |  | 11-046 |  |  | 13-006 |  |  | 09-022 |  | 6 | 14368335M |  |  |  |  |  | 12-054 |  |  | 08-052 |  |  |  |  |  |  |  |  |  |  |  |  |  |  |  |  |  |  |  |  |
| 14368015 |  | Install Pivot for SHMS |  | 5d | 2013-04-01 A | 2013-06-17 A | 14362075a, 14367005, 14368325 FS+22d, 14368174g, 14368173, 3P-07M, 14362075b | 100% |  | 2013-05-01 | 2013-05-07 |  |  |  |  | MECH TECH [80 h]; PLABOR; MECH DES [40 h]; MECH ENG [40 h]; PROCUREMENT<$50K 60 | 18,551.6 | 8,551.6 | 0 | 18551.6 | FENKER H | 1 | 1 | D | HOWARD F | 10-069 | 11-026 | 11-046 | 12-012 | 12-036F | 13-006 | 100 |  | 09-022 |  |  | 14368015 | 0 | 10000 | 1000000 |  |  | 12-054 | 10-076 |  |  |  |  |  |  |  |  |  |  |  |  |  |  |  |  |  |  |  |  |  |  |
| 14368020 |  | Move Pre-Fab Compnts into Hall with road crane |  | 3d | 2013-04-01 A | 2013-08-23 A | 14362015, 14362025, 14362040, 14362050, 14362050a, 14362035, 14362030, 14368015 FS-100d, 14362055, 14368174t, 14362045, 14362035a, 14362020 | 100% |  | 2013-05-08 | 2013-05-10 |  |  |  |  | PROCUREMENT<$50K 60; PROCUREMENT>$50K 69; MECH DES [40 h]; MECH TECH [80 h] | 41,657.2 | 5,657.2 | 22494.888 | 41657.2 | FENKER H | 1 | 1 | D | HOWARD F | 10-069 | 11-026 | 11-046 | 12-012 | 12-036F | 13-006 | 100 |  | 09-022 |  |  | 14368020 | 0 | 36000 | 3600000 | 11-025 |  | 12-054 |  | APP |  |  |  |  | 08-016 | 09-012 |  |  |  |  |  |  |  |  |  |  |  |  |  |  |  |
| 14368027 |  | Install Wheels and Bogies |  | 10d | 2013-04-01 A | 2013-08-30 A | 14368330 FS-100d, 14362050, 14362050a | 100% |  | 2013-08-07 | 2013-08-20 |  |  |  |  | MECH ENG [80 h]; MECH TECH [216 h]; MECH DES [160 h]; PROCUREMENT>$50K 69; PROCUREMENT<$50K 60 | 83,648.16 | 23,648.16 | 83648.16 | 83648.16 | FENKER H | 1 | 1 | D | HOWARD F | 10-069 |  | 11-046 | 12-012 | 12-036F | 13-006 | 100 |  | 09-022 |  |  | 14368027 | 0 | 60000 | 6000000 | 11-025 |  | 12-054 |  | APP |  |  |  |  | 08-016 | 09-012 |  |  |  |  |  |  |  |  |  |  |  |  |  |  |  |
| 14368330 |  | Assemble Main Carriage of Supprt Struct |  | 60d | 2013-04-01 A | 2013-08-30 A | 14362011 FS-125d, 14368020 FS-100d, 14362060 | 100% |  | 2013-05-13 | 2013-08-06 |  |  |  |  | MECH TECH [1040 h]; PROCUREMENT<$50K 60; MECH ENG [200 h]; MSHOP; SUPPLIES & MATERIALS; PLABOR; MECH DES [320 h]; PROCUREMENT>$50K 69 | 621,682.34 | 78,073.6 | 310841.17 | 621682.34 | FENKER H | 1 | 1 | D | HOWARD F | 10-069 |  | 11-046 | 12-012 | 12-036F | 13-006 | 100 |  | 09-022 |  |  | 14368330 | 0 | 500000 | 50000000 |  |  | 12-054 |  | APP | 08-052 |  |  |  | 08-016 | 09-012 |  |  |  |  |  |  |  |  |  |  |  |  |  |  |  |
| 14368280LOE |  | Installation Management P1 |  | 64d | 2013-07-01 A | 2013-08-30 A | 9-130M FS+184d | 100% |  | 2013-08-01 | 2013-10-30 |  |  |  |  | SCIENTIST [226.88 h] | 16,711.41 | 16,612.72 | 15777.54156 | 16530.4768 | FENKER H | 1 | 1 | E | HOWARD F | 10-069 | 11-026 | 11-046 |  |  |  |  |  |  |  |  | 14368280LOE |  |  |  |  |  |  |  |  |  |  |  |  |  |  | 31.25 | 68.75 | 100 | 100 |  |  |  |  |  |  |  |  |  |  |  |
| 14368028 |  | Construct REAR Access Platform & Shield Wall |  | 13d | 2013-08-30 A | 2013-08-30 A | 14368330 | 100% |  | 2013-10-31 | 2013-11-18 |  |  |  |  | MECH DES [160 h]; MECH TECH [200 h]; PROCUREMENT<$50K 60; MECH ENG [80 h] | 23,645.6 | 22,914.4 | 72359.74 | 12984.653067 | FENKER H | 1 | 1 | H | HOWARD F | 10-069 | 11-026 | 11-046 |  |  | 13-006 |  |  | 09-022 |  |  | 14368028 |  |  |  | 11-025 |  | 12-054 |  | APP |  |  |  |  |  |  |  |  |  |  |  |  |  |  |  |  |  |  |  |  |  |
| 14368115 |  | Prep for Vac & pressure systems Safty Review |  | 10d | 2013-08-30 A | 2013-08-30 A | 9-140M FS+310d | 100% |  | 2015-01-07 | 2015-01-21 |  |  |  |  | MECH ENG [80 h] | 5,973.6 | 5,788.8 | 5788.8 | 5788.8 | FENKER H | 1 | 1 | H | HOWARD F | 10-069 | 11-026 | 11-046 | 12-012 | 12-036F |  |  |  |  |  |  | 14368115 |  |  |  |  |  | 12-054 |  |  |  |  |  |  |  |  |  |  |  |  |  |  |  |  |  |  |  |  |  |  |  |
| 14368182M |  | Cryogens Available from ESR or CHL | milestone | 0d | 2013-08-30 A | 2013-08-30 A | 9-130M FS+184d, 9-120M FS+160d | 100% |  | 2013-09-03 | 2013-09-03 |  |  |  |  |  |  |  |  | 0 | FENKER H | 1 | 1 | M | HOWARD F | 10-069 | 11-026 | 11-046 | 12-012 | 12-036F |  |  |  | 09-022 |  |  | 14368182M |  |  |  |  | XX |  |  |  |  | Pat | 12-003 |  |  |  |  |  |  |  |  |  |  |  |  |  |  |  |  |  |  |
| 14368185 |  | Cool Down HMS Dipole |  | 5d | 2013-08-30 A | 2013-08-30 A | 14368182M, 14368180 | 100% |  | 2013-09-03 | 2013-09-09 |  |  |  |  |  |  |  |  | 0 | FENKER H | 1 | 1 | Z | HOWARD F | 10-069 | 11-026 | 11-046 | 12-012 | 12-036F |  |  |  | 09-022 |  |  | 14368185 |  |  |  |  | XX |  |  |  |  | Pat | 12-003 |  |  |  |  |  |  |  |  |  |  |  |  |  |  |  |  |  |  |
| 14368190 |  | Cool Down HMS Q1 |  | 10d | 2013-08-30 A | 2013-08-30 A | 14368185 | 100% |  | 2013-09-10 | 2013-09-23 |  |  |  |  |  |  |  |  | 0 | FENKER H | 1 | 1 | Z | HOWARD F | 10-069 | 11-026 | 11-046 | 12-012 | 12-036F |  |  |  | 09-022 |  |  | 14368190 |  |  |  |  |  |  |  |  |  | Pat | 12-003 |  |  |  |  |  |  |  |  |  |  |  |  |  |  |  |  |  |  |
| 14368195 |  | Cool Down HMS Q2 |  | 10d | 2013-08-30 A | 2013-08-30 A | 14368190 | 100% |  | 2013-09-24 | 2013-10-07 |  |  |  |  |  |  |  |  | 0 | FENKER H | 1 | 1 | Z | HOWARD F | 10-069 | 11-026 | 11-046 | 12-012 | 12-036F |  |  |  | 09-022 |  |  | 14368195 |  |  |  |  |  |  |  |  |  | Pat | 12-003 |  |  |  |  |  |  |  |  |  |  |  |  |  |  |  |  |  |  |
| 14368200 |  | Cool Down HMS Q3 |  | 10d | 2013-08-30 A | 2013-08-30 A | 14368195 | 100% |  | 2013-10-08 | 2013-10-21 |  |  |  |  |  |  |  |  | 0 | FENKER H | 1 | 1 | Z | HOWARD F | 10-069 | 11-026 | 11-046 | 12-012 | 12-036F |  |  |  | 09-022 |  |  | 14368200 |  |  |  |  |  |  |  |  |  | Pat | 12-003 |  |  |  |  |  |  |  |  |  |  |  |  |  |  |  |  |  |  |
| 14368205 |  | Comission HMS Dipole at 3000 amps |  | 10d | 2013-08-30 A | 2013-08-30 A | 14368200 | 100% |  | 2013-10-22 | 2013-11-04 |  |  |  |  |  |  |  |  | 0 | FENKER H | 1 | 1 | Z | HOWARD F | 10-069 | 11-026 | 11-046 | 12-012 | 12-036F |  |  |  | 09-022 |  |  | 14368205 |  |  |  |  |  |  |  |  |  | Pat | 12-003 |  |  |  |  |  |  |  |  |  |  |  |  |  |  |  |  |  |  |
| 14368210 |  | Prepare LCW for SHMS DCPS Testing |  | 10d | 2013-08-30 A | 2013-08-30 A | 14368185, 14368207 | 100% |  | 2013-09-18 | 2013-10-01 |  |  |  |  | MECH TECH [160 h]; MECH ENG [80 h]; SUPPLIES & MATERIALS | 18,492.33 | 13,126.4 | 18044.09 | 18044.09 | FENKER H | 1 | 1 | H | HOWARD F | 10-069 | 11-026 | 11-046 | 12-012 | 12-036F |  |  |  | 09-022 |  |  | 14368210 |  |  |  |  |  |  |  |  |  | Pat | 12-003 |  |  |  |  |  |  |  |  |  |  |  |  |  |  |  |  |  |  |
| 14368215 |  | Prepare AC Power for SHMS DCPS Testing |  | 10d | 2013-08-30 A | 2013-08-30 A | 14368185 | 100% |  | 2013-09-10 | 2013-09-23 |  |  |  |  | ELEC TECH [160 h]; ELEC ENG [80 h]; SUPPLIES & MATERIALS | 23,759.38 | 13,111.2 | 23353.78 | 23353.78 | FENKER H | 1 | 1 | H | HOWARD F | 10-069 | 11-026 | 11-046 | 12-012 | 12-036F |  |  |  | 09-022 |  |  | 14368215 |  |  |  |  |  |  |  |  |  | Pat | 12-003 |  |  |  |  |  |  |  |  |  |  |  |  |  |  |  |  |  |  |
| 14368220 |  | Connect HMS Q1 to SHMS DCPS #1 |  | 2d | 2013-08-30 A | 2013-08-30 A | 14315075, 14368190 | 100% |  | 2013-09-24 | 2013-09-25 |  |  | start on or after 2011-05-26 |  | ELEC TECH [32 h] | 1,457.28 | 1,457.28 | 1412.16 | 1412.16 | FENKER H | 1 | 1 | H | HOWARD F | 10-069 | 11-026 | 11-046 | 12-012 | 12-036F |  |  |  | 09-022 |  |  | 14368220 |  |  |  |  |  |  |  |  |  | Pat | 12-003 |  |  |  |  |  |  |  |  |  |  |  |  |  |  |  |  |  |  |
| 14368225 |  | Test Power Supply DCPS #1 |  | 3d | 2013-08-30 A | 2013-08-30 A | 14368210, 14368220, 14368215 | 100% |  | 2013-10-02 | 2013-10-04 |  |  |  |  | MECH ENG [48 h] | 3,584.16 | 3,473.28 | 3365.76 | 3365.76 | FENKER H | 1 | 1 | H | HOWARD F | 10-069 | 11-026 | 11-046 | 12-012 | 12-036F |  |  |  | 09-022 |  |  | 14368225 |  |  |  |  |  |  |  |  |  | Pat | 12-003 |  |  |  |  |  |  |  |  |  |  |  |  |  |  |  |  |  |  |
| 14368230 |  | Connect HMS Q1 to SHMS DCPS #2 |  | 2d | 2013-08-30 A | 2013-08-30 A | 14368225 | 100% |  | 2013-10-07 | 2013-10-08 |  |  |  |  | ELEC TECH [32 h] | 1,503.68 | 1,457.28 | 1412.16 | 1412.16 | FENKER H | 1 | 1 | H | HOWARD F | 10-069 | 11-026 | 11-046 | 12-012 | 12-036F |  |  |  | 09-022 |  |  | 14368230 |  |  |  |  |  |  |  |  |  | Pat | 12-003 |  |  |  |  |  |  |  |  |  |  |  |  |  |  |  |  |  |  |
| 14368235 |  | Test Power Supply DCPS #2 |  | 3d | 2013-08-30 A | 2013-08-30 A | 14368230 | 100% |  | 2013-10-09 | 2013-10-11 |  |  |  |  | MECH ENG [48 h] | 3,584.16 | 3,473.28 | 3365.76 | 3365.76 | FENKER H | 1 | 1 | H | HOWARD F | 10-069 | 11-026 | 11-046 | 12-012 | 12-036F |  |  |  | 09-022 |  |  | 14368235 |  |  |  |  |  |  |  |  |  | Pat | 12-003 |  |  |  |  |  |  |  |  |  |  |  |  |  |  |  |  |  |  |
| 14368240 |  | Connect HMS Dipole to SHMS DCPS #3 |  | 2d | 2013-08-30 A | 2013-08-30 A | 14368235, 14368205, 14315085 | 100% |  | 2013-11-05 | 2013-11-06 |  |  |  |  | ELEC TECH [32 h] | 1,503.68 | 1,457.28 | 1457.28 | 1457.28 | FENKER H | 1 | 1 | H | HOWARD F | 10-069 | 11-026 | 11-046 | 12-012 | 12-036F |  |  |  | 09-022 |  |  | 14368240 |  |  |  |  |  | 12-054 |  |  |  | Pat | 12-003 |  |  |  |  |  |  |  |  |  |  |  |  |  |  |  |  |  |  |
| 14368245 |  | Test Power Supply DCPS #3 |  | 3d | 2013-08-30 A | 2013-08-30 A | 14368240 | 100% |  | 2013-11-07 | 2013-11-11 |  |  |  |  | MECH ENG [48 h] | 3,584.16 | 3,473.28 | 3473.28 | 3473.28 | FENKER H | 1 | 1 | H | HOWARD F | 10-069 | 11-026 | 11-046 | 12-012 | 12-036F |  |  |  | 09-022 |  |  | 14368245 |  |  |  |  |  | 12-054 |  |  |  | Pat | 12-003 |  |  |  |  |  |  |  |  |  |  |  |  |  |  |  |  |  |  |
| 14368250 |  | Connect HMS Dipole to SHMS DCPS #4 |  | 2d | 2013-08-30 A | 2013-08-30 A | 14368245 | 100% |  | 2013-11-12 | 2013-11-13 |  |  |  |  | ELEC TECH [32 h] | 1,503.68 | 1,457.28 | 1457.28 | 1457.28 | FENKER H | 1 | 1 | H | HOWARD F | 10-069 | 11-026 | 11-046 | 12-012 | 12-036F |  |  |  | 09-022 |  |  | 14368250 |  |  |  |  |  | 12-054 |  |  |  | Pat | 12-003 |  |  |  |  |  |  |  |  |  |  |  |  |  |  |  |  |  |  |
| 14368255 |  | Test Power Supply DCPS #4 |  | 3d | 2013-08-30 A | 2013-08-30 A | 14368250 | 100% |  | 2013-11-14 | 2013-11-18 |  |  |  |  | MECH ENG [48 h] | 3,584.16 | 3,473.28 | 3473.28 | 3473.28 | FENKER H | 1 | 1 | H | HOWARD F | 10-069 | 11-026 | 11-046 | 12-012 | 12-036F |  |  |  | 09-022 |  |  | 14368255 |  |  |  |  |  | 12-054 |  |  |  | Pat | 12-003 |  |  |  |  |  |  |  |  |  |  |  |  |  |  |  |  |  |  |
| 14368260 |  | Connect HMS Dipole to SHMS DCPS #5 |  | 2d | 2013-08-30 A | 2013-08-30 A | 14368255 | 100% |  | 2013-11-19 | 2013-11-20 |  |  |  |  | ELEC TECH [32 h] | 1,503.68 | 1,457.28 | 1457.28 | 1457.28 | FENKER H | 1 | 1 | H | HOWARD F | 10-069 | 11-026 | 11-046 | 12-012 | 12-036F |  |  |  | 09-022 |  |  | 14368260 |  |  |  |  |  | 12-054 |  |  |  | Pat | 12-003 |  |  |  |  |  |  |  |  |  |  |  |  |  |  |  |  |  |  |
| 14368265 |  | Test Power Supply DCPS #5 |  | 3d | 2013-08-30 A | 2013-08-30 A | 14368260 | 100% |  | 2013-11-21 | 2013-11-25 |  |  |  |  | MECH ENG [48 h] | 3,584.16 | 3,473.28 | 3473.28 | 3473.28 | FENKER H | 1 | 1 | H | HOWARD F | 10-069 | 11-026 | 11-046 | 12-012 | 12-036F |  |  |  | 09-022 |  |  | 14368265 |  |  |  |  |  | 12-054 |  |  |  | Pat | 12-003 |  |  |  |  |  |  |  |  |  |  |  |  |  |  |  |  |  |  |
| 14368333 |  | Install Cryo Boom Support |  | 2d | 2013-08-30 A | 2013-08-30 A | 14368330, 14364050 | 100% |  | 2013-10-31 | 2013-11-01 |  |  |  |  | PROCUREMENT<$50K 60; MECH TECH [160 h]; MECH DES [80 h] | 26,675.2 | 11,314.4 | 26314.4 | 26314.4 | FENKER H | 1 | 1 | H | HOWARD F | 10-069 |  | 11-046 | 12-012 | 12-036F | 13-006 | 100 |  | 09-022 |  |  | 14368333 | 0 | 15000 | 1500000 |  |  | 12-054 |  | APP | 08-052 |  |  |  | 08-016 | 09-012 |  |  |  |  | 12-022 |  |  |  |  |  |  |  |  |  |  |
| 14368383 |  | Procure SHMS Platform Assembly Parts |  | 99d | 2013-08-30 A | 2013-08-30 A | 9-130M FS+43d | 100% |  | 2014-02-13 | 2014-07-03 |  |  |  |  | PROCUREMENT>$50K 69 | 87,898.23 |  | 87898.23 | 87898.23 | FENKER H | 1 | 1 | D | HOWARD F | 10-069 |  | 11-046 | 12-012 | 12-036F |  | 100 |  | 09-022 |  |  | 14368383 | 0 | 87898.23 | 8789823 |  |  |  |  |  | 08-052 |  |  |  |  |  |  |  |  |  | 12-022 |  |  |  |  |  |  |  |  |  |  |
| 14368425 |  | Install QR Magnets (Notebook) |  | 50d | 2013-08-30 A | 2013-08-30 A | 9-130M FS+235d, 9-120M FS+150d, 14352005 | 100% |  | 2013-09-12 | 2013-11-20 |  |  |  |  | MECH DES [80 h]; MECH TECH [160 h] | 11,581.39 | 11,314.4 | 10964 | 10964 | FENKER H | 1 | 1 | H | HOWARD F | 10-069 |  | 11-046 | 12-012 |  |  |  |  |  |  |  | 14368425 |  |  |  |  |  |  |  |  |  |  |  | NB |  |  |  |  |  |  |  |  |  |  |  |  |  |  |  |  |  |
| 14368510 |  | Re-Baseline Actuals Adjustment |  | 1d | 2013-08-30 A | 2013-08-30 A |  | 100% |  | 2013-09-03 | 2013-09-03 |  |  |  |  | PROCUREMENT>$50K 69 NO ESCALATION | -370,343.31 |  |  |  |  |  |  |  |  |  |  |  |  |  |  | 100 | ADJ |  |  |  |  |  |  |  |  |  |  |  |  |  |  |  |  |  |  |  |  |  |  |  |  |  |  |  |  |  |  |  |  |  |
| 14368120M |  | Comp safety Review of vacuum & pressure Vessel systems Implementn | milestone | 0d | 2013-08-30 A | 2013-08-30 A | 14368115 | 100% |  | 2015-01-21 | 2015-01-21 |  |  |  |  |  |  |  |  | 0 | FENKER H | 1 | 1 | M | HOWARD F | 10-069 | 11-026 | 11-046 | 12-012 | 12-036F |  |  |  |  |  | 6 | 14368120M |  |  |  |  |  | 12-054 |  |  |  |  |  |  |  |  |  |  |  |  |  |  |  |  |  |  |  |  |  |  |  |
| 24368040 |  | Procure SHMS Steel Platforms and Stairs (Box O Parts) Part A |  | 77d | 2013-09-03 A | 2013-10-21 A | 9-130M FS+228d | 100% |  | 2013-09-03 | 2013-12-20 |  |  |  | 8/5 M-F w/JLAB Holidays ReBaseline | PROCUREMENT>$50K 69 | 2,266 |  |  | 2266 | FENKER H | 1 | 1 | D | HOWARD F | 10-069 |  | 11-046 | 12-012 | 12-036F | 13-006F | 100 |  | 09-022 |  |  |  | 0 | 2266 | 226600 |  |  |  |  |  | 08-052 |  |  |  |  |  |  |  |  |  | 12-022 | 24368383 | 1 | EJ | 13-015 | PR | OB |  |  |  |  |
| 24368050 |  | Install SHMS Steel Procurement |  | 20d | 2013-09-03 A | 2013-11-01 | 9-130M FS+228d | 100% | 0d | 2013-09-03 | 2013-09-30 | 252d | 20d |  | 8/5 M-F w/JLAB Holidays ReBaseline | PROCUREMENT>$50K 69; PROCUREMENT<$50K 60 | 174,707.4 |  |  | 0 | FENKER H | 1 | 1 | D | HOWARD F | 10-069 | 11-026 | 11-046 | 12-012 | 12-036F | 13-006 | 100 |  | 09-022 |  |  |  | 0 | 174707.4 | 17470740 |  |  | 12-054 | 10-076 |  |  |  |  |  |  |  |  |  |  |  |  | 24368015 | 1 | EV | 13-015 | PR | OB | 174707.4 | EJ |  |  |
| 24368065 |  | Forming and Pouring Work for Concrete - Procurement |  | 62d | 2013-09-03 A | 2013-11-27 | 9-130M FS+228d, 24368050 FS-20d | 50% | 19d |  |  | 232d | 0d |  | 8/5 M-F w/JLAB Holidays ReBaseline | PROCUREMENT<$50K 60 NO ESCALATION FY14; PROCUREMENT>$50K 69 NO ESCALATION FY14 | 309,508.19 |  |  | 92852.46 | FENKER H | 1 | 1 | S | HOWARD F | 10-069 |  | 11-046 | 12-012 | 12-036 | 13-006 | 100 |  | 09-022 |  |  |  | 154754.095 | 154754.095 | 15475409.5 | 11-025 |  | 12-054 |  | APP | 08-052 |  |  | ST | 08-016 | 09-012 |  |  |  |  |  | 24368355 | 2 | EJ | 13-015 | PR | OB | 61901.64 | EJ | EJ |  |
| 24368065a |  | Forming and Pouring Work for Concrete - Labor FY13 |  | 20d | 2013-09-03 A | 2013-11-27 | 9-130M FS+228d | 50% | 19d | 2013-09-03 | 2013-09-30 | 391d | 43d |  | 8/5 M-F w/JLAB Holidays ReBaseline | MECH DES [51.61 h]; MECH ENG [25.81 h] | 4,433.07 | 3,127.11 |  | 1329.9207621 | FENKER H | 1 | 1 | S | HOWARD F | 10-069 |  | 11-046 | 12-012 | 12-036 | 13-006 |  |  | 09-022 |  |  |  |  |  |  | 11-025 |  | 12-054 |  | APP | 08-052 |  |  | ST | 08-016 | 09-012 |  |  |  |  |  | 24368355 | 2 | EJ | 13-015 | PR |  | 886.6138414 | EJ | EJ |  |
| 24368065b |  | Forming and Pouring Work for Concrete - Labor FY14 |  | 42d | 2013-09-03 A | 2013-11-27 | 24368065a FS-105d | 50% | 19d | 2013-10-01 | 2013-11-27 | 305d | 0d |  | 8/5 M-F w/JLAB Holidays ReBaseline | MECH DES [108.39 h]; MECH ENG [54.19 h] | 9,606.86 | 6,566.84 |  | 2882.0556576 | FENKER H | 1 | 1 | S | HOWARD F | 10-069 |  | 11-046 | 12-012 | 12-036 | 13-006 |  |  | 09-022 |  |  |  |  |  |  | 11-025 |  | 12-054 |  | APP | 08-052 |  |  | ST | 08-016 | 09-012 |  |  |  |  |  | 24368355 | 2 | EJ | 13-015 | PR |  | 1921.3704384 | EJ | EJ | 14-001 |

Notes:
- 14368175: Steps: pull-back cables (done); Cut Coaxial xfer line and preserve (done); Remove/Preserve C can (done); Remove/Preserve Perimeter Line (done); Remove/Preserve Gas Lines (done); Dismantle field join A can to B can (done); lay cables in relocated tray (done)
- 14368027: Explanation: Removed 13.0 weeks each of ME and MT to keep CR11-046 a Level / 5
- 14368028: Entry Criteria: Ext Pred: COMPLETE MAGNET CONTRACT
- 14368425: Explanation: Budget contains 2 weeks of Survey & Alignment Tech in / the Mech Tech Budget. 12Aug2010 PMC
- 24368065: Steps: Base Pour Complete (done); Lower wall pour complete (done); Upper wall pour complete (done); B4C pour complete; Door, walland roof pours complete; Shield House complete - site clean
- 24368065a: Steps: Base Pour Complete (done); Lower wall pour complete (done); Upper wall pour complete (done); B4C pour complete; Door, walland roof pours complete; Shield House complete - site clean
- 24368065b: Steps: Base Pour Complete (done); Lower wall pour complete (done); Upper wall pour complete (done); B4C pour complete; Door, walland roof pours complete; Shield House complete - site clean

| ID | Activity | Type | Duration | Start | Finish | Predecessors | Complete | Remaining | Planned start | Planned finish | Total float | Free float | Calendar | Resources | Cost | Actual cost | Original Activity ID Rebaseline | Howard's Code | Remaining Material Cost Based on % Compl | Claimed Material Cost Based on % Complet | Initial Claimed Material Calc | Claimed Material Divider | MONTHLY EV COST | PRIOR MONTH EV COST | RESP - Responsibility | STRT%COMP for CM EVM | FNSH%COMP for CM EVM | Advance Purchase Plan > 500K | EVMS Reporting Codes | CAM RESPONSIBLE | CR 08-052 | Activities with Steps | CR 09-022 | CR 10-069 | CR 11-025 | CR 11-046 | CR 12-012 | CR 12-036 | CR 12-054 | CR 13-006 | BOE Procurement | BOE Labor | BOE Expenses | CR 13-015 | Post Rebaseline | Obligated Prior to Rebaseline | CR 14-001 | CR 10-076 | BOE NOTES | CR 11-026 | LOE % Pre Calc | LOE % | LOE Divider | LOE Multiplier | CR 12-022 | Milestone Level | 12 GEV MAJOR PROCUREMENT CATAGORY | CR 10-025 | CR 09-012 | CR 08-016 | Pat's Code | CR 12-003 | CR 11-017 | Inter Project Link (IPL) | CR 07-034 | CR 08-048 | CR 07-024 | CR 10-063 | CR 10-074 |
| --- | --- | --- | --- | --- | --- | --- | --- | --- | --- | --- | --- | --- | --- | --- | --- | --- | --- | --- | --- | --- | --- | --- | --- | --- | --- | --- | --- | --- | --- | --- | --- | --- | --- | --- | --- | --- | --- | --- | --- | --- | --- | --- | --- | --- | --- | --- | --- | --- | --- | --- | --- | --- | --- | --- | --- | --- | --- | --- | --- | --- | --- | --- | --- | --- | --- | --- | --- | --- | --- |
| 24368070 | Procure Concrete for Shield House - Procurement |  | 62d | 2013-09-03 A | 2013-11-27 | 24368065 FS-62d | 50% | 19d |  |  | 189d | 0d | 8/5 M-F w/JLAB Holidays ReBaseline | PROCUREMENT<$50K 60 NO ESCALATION FY14; PROCUREMENT>$50K 69 NO ESCALATION FY14 | 213,025 |  | 24368360 | 2 | 106512.5 | 106512.5 | 10651250 | 100 | 63907.5 | 42605 | FENKER H | 1 | 1 | APP | S | HOWARD F | 08-052 | ST | 09-022 | 10-069 | 11-025 | 11-046 | 12-012 | 12-036 | 12-054 | 13-006 | EJ | EJ | EJ | 13-015 | PR | OB |  |  |  |  |  |  |  |  |  |  |  |  |  |  |  |  |  |  |  |  |  |  |  |
| 24368070a | Procure Concrete for Shield House - Labor FY13 |  | 20d | 2013-09-03 A | 2013-11-27 | 24368065a FS-62d, 24368065b FS-62d | 50% | 19d | 2013-09-03 | 2013-09-30 | 565d | 86d | 8/5 M-F w/JLAB Holidays ReBaseline | MECH TECH [25.81 h] | 1,183.65 | 834.9 | 24368360 | 2 |  |  |  |  | 355.09398 | 236.72932 | FENKER H | 1 | 1 | APP | S | HOWARD F | 08-052 | ST | 09-022 | 10-069 | 11-025 | 11-046 | 12-012 | 12-036 | 12-054 | 13-006 | EJ | EJ | EJ | 13-015 | PR |  |  |  |  |  |  |  |  |  |  |  |  |  |  |  |  |  |  |  |  |  |  |  |  |
| 24368070b | Procure Concrete for Shield House - Labor FY14 |  | 42d | 2013-09-03 A | 2013-11-27 | 24368070a FS-105d, 24368065a FS-62d, 24368065b FS-62d | 50% | 19d | 2013-10-01 | 2013-11-27 | 479d | 344d | 8/5 M-F w/JLAB Holidays ReBaseline | MECH TECH [54.19 h] | 2,564.27 | 1,752.92 | 24368360 | 2 |  |  |  |  | 769.28124 | 512.85416 | FENKER H | 1 | 1 | APP | S | HOWARD F | 08-052 | ST | 09-022 | 10-069 | 11-025 | 11-046 | 12-012 | 12-036 | 12-054 | 13-006 | EJ | EJ | EJ | 13-015 | PR |  | 14-001 |  |  |  |  |  |  |  |  |  |  |  |  |  |  |  |  |  |  |  |  |  |  |
| 24368120 | Long-lead procurements for AC Pwr for Support Structure |  | 20d | 2013-09-03 A | 2013-10-21 A | 9-130M FS+228d, 24368070 FS-62d | 100% |  | 2013-09-03 | 2013-09-30 |  |  | 8/5 M-F w/JLAB Holidays ReBaseline | PROCUREMENT>$50K 69 | 12,985 |  | 24368315 | 3 | 0 | 12985 | 1298500 | 100 | 12985 |  | FENKER H | 1 | 1 | APP | D | HOWARD F | 08-052 |  | 09-022 | 10-069 |  | 11-046 | 12-012 | 12-036 | 12-054 | 13-006 | EJ | EJ | EJ | 13-015 | PR | OB |  | 10-076 |  |  |  |  |  |  |  |  |  |  |  |  |  |  |  |  |  |  |  |  |  |
| 24368170 | Remove and Preserve C-Can and Lines |  | 20d | 2013-09-03 A | 2013-09-30 A | 9-130M FS+228d | 100% |  |  |  |  |  | 8/5 M-F w/JLAB Holidays ReBaseline | MECH DES [48 h]; MECH TECH [176 h] | 10,457.44 | 10,457.44 | 24368175 | 4 |  |  |  |  | 0 | 10457.44 | FENKER H | 1 | 1 |  | H | HOWARD F |  |  | 09-022 | 10-069 | 11-025 | 11-046 | 12-012 | 12-036F | 12-054 | 13-006 |  | EJ |  | 13-015 | PR |  |  |  | NO RESOURCES | 11-026 |  |  |  |  |  |  |  |  |  |  |  |  |  |  |  |  |  |  |  |
| 24368190 | Complete Readiness Review for SHMS DCPS Testing FY13 |  | 33d | 2013-09-03 A | 2014-01-15 | 9-130M FS+228d | 50% | 44d | 2013-09-03 | 2013-10-17 | 272d | 9d | 8/5 M-F w/JLAB Holidays ReBaseline | MECH ENG [12.12 h]; MECH DES [12.12 h]; SCIENTIST [12.12 h] | 2,392.25 | 1,187.62 | 24368207 | 5 |  |  |  |  | 0 | 1181.2758 | FENKER H | 1 | 1 |  | H | HOWARD F |  |  |  |  |  |  |  |  |  | 13-006 |  | PE |  | 13-015 | PR |  |  |  |  |  |  |  |  |  |  |  |  |  |  |  |  |  |  |  |  |  |  |  |  |
| 24368190a | Complete Readiness Review for SHMS DCPS Testing FY14 |  | 13d | 2013-09-03 A | 2014-01-15 | 24368190 FS-100d | 50% | 44d | 2013-10-01 | 2013-10-17 | 272d | 9d | 8/5 M-F w/JLAB Holidays ReBaseline | MECH ENG [7.88 h]; MECH DES [7.88 h]; SCIENTIST [7.88 h] | 1,585.06 | 772.15 | 24368207 | 5 |  |  |  |  | 0 | 792.531 | FENKER H | 1 | 1 |  | H | HOWARD F |  |  |  |  |  |  |  |  |  | 13-006 |  | PE |  | 13-015 | PR |  | 14-001 |  |  |  |  |  |  |  |  |  |  |  |  |  |  |  |  |  |  |  |  |  |  |
| 24368575LOE | Installation Management P1 |  | 20d | 2013-09-03 A | 2013-09-30 A | 9-130M FS+228d | 100% |  |  |  |  |  | 8/5 M-F w/JLAB Holidays ReBaseline | SCIENTIST [37.5 h]; MECH ENG [75 h] | 8,159.25 | 8,159.25 | 24368280LOE | 90 |  |  |  |  | 0 | 8159.25 | FENKER H | 1 | 1 |  | E | HOWARD F |  |  |  | 10-069 |  | 11-046 |  |  |  | 13-006 |  | PE |  | 13-015 | PR |  |  |  |  | 11-026 |  |  |  |  |  |  |  |  |  |  |  |  |  |  |  |  |  |  |  |
| 24368052 | Align Wheels and Bogies on Support Structure |  | 4d | 2013-09-16 A | 2013-09-30 A | 24368050 FS-20d | 100% |  | 2013-10-01 | 2013-10-04 |  |  | 8/5 M-F w/JLAB Holidays ReBaseline | MECH TECH [80 h] | 3,785.6 | 3,668.8 | 24368052 | 1 |  |  |  |  | 0 | 3668.8 | FENKER H | 1 | 1 |  | H | HOWARD F |  |  | 09-022 | 10-069 |  | 11-046 | 12-012 | 12-036F | 12-054 | 13-006 | EV | EJ |  | 13-015 | PR |  |  | 10-076 |  | 11-026 |  |  |  |  |  |  |  |  |  |  |  |  |  |  |  |  |  |  |  |
| 24368580LOE | Installation Management P2 |  | 247d | 2013-10-01 A | 2014-09-30 | 24368575LOE | 9% | 224d | 2013-11-01 | 2014-10-31 | 439d | 0d | 8/5 M-F w/JLAB Holidays ReBaseline | SCIENTIST [440 h]; MECH ENG [880 h] | 98,788.8 | 9,198.96 | 24368285LOE | 90 |  |  |  |  | 9197.23728 |  | FENKER H | 1 | 1 |  | E | HOWARD F |  |  |  | 10-069 |  | 11-046 |  |  |  | 13-006 |  | PE |  | 13-015 | PR |  | 14-001 |  |  | 11-026 | 90.6882591 | 9.31174089 | 100 | 100 |  |  |  |  |  |  |  |  |  |  |  |  |  |  |  |
| 24368080 | Concrete Hardening Period |  | 30d | 2013-11-04 | 2013-12-17 | 24368070 FS-18d |  |  |  |  | 189d | 0d | 8/5 M-F w/JLAB Holidays ReBaseline |  |  |  | 24368365 | 2 |  |  |  |  | 0 |  | FENKER H | 1 | 1 | APP | Z | HOWARD F | 08-052 |  | 09-022 | 10-069 | 11-025 | 11-046 | 12-012 | 12-036 | 12-054 | 13-006 |  | PE |  | 13-015 | PR |  |  |  | NO RESOURCES |  |  |  |  |  |  |  |  |  |  |  |  |  |  |  |  |  |  |  |  |
| 24368180 | Pre-Alignment SHMS Cryo Supports |  | 3d | 2013-12-02 | 2013-12-04 | 24368065, 24368065b |  |  |  |  | 305d | 67d | 8/5 M-F w/JLAB Holidays ReBaseline | MECH TECH [24 h] | 1,135.68 |  | 24368095 | 4 |  |  |  |  | 0 |  | FENKER H | 1 | 1 |  | H | HOWARD F |  |  | 09-022 | 10-069 |  | 11-046 | 12-012 | 12-036 | 12-054 | 13-006 |  | EJ |  | 13-015 | PR |  | 14-001 |  |  | 11-026 |  |  |  |  | 12-022 |  |  |  |  |  |  |  |  |  |  |  |  |  |  |
| 24368060 | Construct REAR Access Platform & Shield Wall |  | 75d | 2013-12-05 | 2014-04-01 | 9-140M FS+45d |  |  |  |  | 279d | 0d | 8/5 M-F w/JLAB Holidays ReBaseline | MECH DES [160 h]; MECH TECH [200 h]; MECH ENG [80 h]; PROCUREMENT<$50K 60 | 74,668.25 |  | 24368028 | 2 | 51022.65 | 0 | 0 | 100 | 0 |  | FENKER H | 1 | 1 | APP | D | HOWARD F |  |  | 09-022 | 10-069 | 11-025 | 11-046 |  |  | 12-054 | 13-006 | PE | PE |  | 13-015 | PR |  | 14-001 |  |  | 11-026 |  |  |  |  |  |  |  |  |  |  |  |  |  |  |  |  |  |  |  |
| 24368495 | Adjust Compton Elevation (Notebook) |  | 19d | 2013-12-16 | 2014-01-22 | 24368485 FS-162d |  |  |  |  | 475d | 0d | 8/5 M-F w/JLAB Holidays ReBaseline | MSHOP; MECH DES [80 h]; MECH TECH [360 h] | 26,298.7 |  | 24368420 | 8 |  |  |  |  | 0 |  | FENKER H | 1 | 1 |  | S | HOWARD F |  | ST |  | 10-069 |  | 11-046 | 12-012 |  | 12-054 | 13-006 |  | EJ | EJ | 13-015 | PR |  | 14-001 |  |  |  |  |  |  |  |  |  |  |  |  |  |  |  |  |  |  |  |  |  |  |
| 24368455 | Install QR Magnets |  | 19d | 2013-12-17 | 2014-01-23 | 9-140M FS+53d |  |  |  |  | 479d |  | 8/5 M-F w/JLAB Holidays ReBaseline | MECH DES [80 h]; MECH TECH [160 h] | 11,675.2 |  | 24368425 | 8 |  |  |  |  | 0 |  | FENKER H | 1 | 1 |  | S | HOWARD F |  | ST |  | 10-069 |  | 11-046 | 12-012 |  |  |  |  | EJ |  | 13-015 | PR |  | 14-001 |  |  |  |  |  |  |  |  |  |  |  |  |  |  |  |  |  |  |  |  |  |  |
| 24368085M | Shield House Concrete Work Complete | milestone | 0d | 2013-12-17 | 2013-12-17 | 24368070, 24368080 |  |  |  |  | 189d | 0d | 8/5 M-F w/JLAB Holidays ReBaseline |  |  |  | 24368085M | 2 |  |  |  |  | 0 |  | FENKER H | 1 | 1 |  | M | HOWARD F |  |  | 09-022 | 10-069 | 11-025 | 11-046 | 12-012 | 12-036 | 12-054 | 13-006 |  |  |  | 13-015 | PR |  |  |  |  | 11-026 |  |  |  |  |  | 6 |  |  |  |  |  |  |  |  |  |  |  |  |  |
| 24368090 | Install Boron & Lead Shielding |  | 23d | 2013-12-18 | 2014-01-30 | 24363030aa, 24368085M |  |  |  |  | 189d | 0d | 8/5 M-F w/JLAB Holidays ReBaseline | PROCUREMENT<$50K 60; MECH TECH [560 h]; MECH DES [40 h]; MSHOP; SUPPLIES & MATERIALS | 78,242.27 |  | 24368080a | 2 | 20638 | 0 | 0 | 100 | 0 |  | FENKER H | 1 | 1 | APP | S | HOWARD F | 08-052 | ST | 09-022 | 10-069 | 11-025 | 11-046 |  | 12-036 | 12-054 | 13-006 | EJ | EJ | EJ | 13-015 | PR |  | 14-001 |  |  |  |  |  |  |  |  |  | 4362B | 10-025 |  |  |  |  |  |  |  |  |  |  |  |
| 24368075 | Re-Establish Hall-C Alignment Network After SHMS Assy |  | 3d | 2014-01-02 | 2014-01-06 | 24368070 FS+15d |  |  |  |  | 211d | 22d | 8/5 M-F w/JLAB Holidays ReBaseline | MECH TECH [80 h] | 3,785.6 |  | 24368362 | 2 |  |  |  |  | 0 |  | FENKER H | 1 | 1 | APP | H | HOWARD F |  |  |  |  |  |  |  |  |  | 13-006 | EJ | PE |  | 13-015 | PR |  | 14-001 |  |  |  |  |  |  |  |  |  |  |  |  |  |  |  |  |  |  |  |  |  |  |
| 24368125 | Install Cable Trays of Supprt Struct |  | 22d | 2014-01-02 | 2014-02-03 | 9-140M FS+57d, 24368085M |  |  |  |  | 276d | 34d | 8/5 M-F w/JLAB Holidays ReBaseline | PROCUREMENT>$50K 69; MECH DES [80 h]; MECH TECH [160 h] | 27,871.16 |  | 24368310 | 3 | 16195.96 | 0 | 0 | 100 | 0 |  | FENKER H | 1 | 1 | APP | S | HOWARD F | 08-052 | ST | 09-022 | 10-069 |  | 11-046 | 12-012 | 12-036 | 12-054 | 13-006 | EJ | EJ | PE | 13-015 | PR |  | 14-001 | 10-076 |  |  |  |  |  |  |  |  |  |  | 09-012 |  |  |  |  |  |  |  |  |  |  |
| 24368175 | Install Cryo Boom Support |  | 12d | 2014-01-02 | 2014-01-17 | 24368170 FS+57d |  |  |  |  | 281d | 43d | 8/5 M-F w/JLAB Holidays ReBaseline | MECH DES [80 h]; MECH TECH [160 h]; PROCUREMENT<$50K 60 | 27,153.7 |  | 24368333 | 4 | 15478.5 | 0 | 0 | 100 | 0 |  | FENKER H | 1 | 1 | APP | S | HOWARD F | 08-052 | ST | 09-022 | 10-069 |  | 11-046 | 12-012 | 12-036F | 12-054 | 13-006 | EJ | EJ |  | 13-015 | PR |  | 14-001 |  | NO RESOURCES |  |  |  |  |  | 12-022 |  |  |  | 09-012 | 08-016 |  |  |  |  |  |  |  |  |  |
| 24368015M | Cryogens Available from ESR or CHL | milestone | 0d | 2014-01-03 | 2014-01-03 | 9-140M FS+60d |  |  |  |  | 251d | 0d | 8/5 M-F w/JLAB Holidays ReBaseline |  |  |  | 24368182M | 0 |  |  |  |  | 0 |  | FENKER H | 1 | 1 |  | M | HOWARD F |  |  | 09-022 | 10-069 |  | 11-046 | 12-012 | 12-036F |  | 13-006F |  |  |  | 13-015 | PR |  |  |  |  | 11-026 |  |  |  |  |  |  |  |  |  |  | Pat | 12-003 |  |  |  |  |  |  |  |
| 24368020 | Cool Down HMS Dipole |  | 5d | 2014-01-03 | 2014-01-09 | 24368015M |  |  |  |  | 251d | 0d | 8/5 M-F w/JLAB Holidays ReBaseline |  |  |  | 24368185 | 0 |  |  |  |  | 0 |  | FENKER H | 1 | 1 |  | Z | HOWARD F |  |  | 09-022 | 10-069 |  | 11-046 | 12-012 | 12-036F |  | 13-006F |  |  |  | 13-015 | PR |  |  |  | NO RESOURCES | 11-026 |  |  |  |  |  |  |  |  |  |  | Pat | 12-003 |  |  |  |  |  |  |  |
| 24368115 | Install LCW for Supprt Struct |  | 39d | 2014-01-06 | 2014-02-28 | 24368070 FS+17d |  |  |  |  | 257d | 15d | 8/5 M-F w/JLAB Holidays ReBaseline | ELEC TECH [160 h]; SUPPLIES & MATERIALS; PROCUREMENT>$50K 69; MECH TECH [400 h] | 56,536.09 |  | 24368317 | 3 | 24765.6 | 0 | 0 | 100 | 0 |  | FENKER H | 1 | 1 | APP | S | HOWARD F | 08-052 | ST | 09-022 | 10-069 |  | 11-046 | 12-012 | 12-036 | 12-054 | 13-006 | EJ | EJ | EJ | 13-015 | PR |  | 14-001 | 10-076 |  |  |  |  |  |  |  |  |  |  |  |  |  |  |  |  |  |  |  |  |  |
| 24368025 | Cool Down HMS Q1 |  | 6d | 2014-01-10 | 2014-01-17 | 24368020 |  |  |  |  | 251d | 0d | 8/5 M-F w/JLAB Holidays ReBaseline |  |  |  | 24368190 | 0 |  |  |  |  | 0 |  | FENKER H | 1 | 1 |  | Z | HOWARD F |  |  | 09-022 | 10-069 |  | 11-046 | 12-012 | 12-036F |  | 13-006F |  |  |  | 13-015 | PR |  |  |  | NO RESOURCES | 11-026 |  |  |  |  |  |  |  |  |  |  | Pat | 12-003 |  |  |  |  |  |  |  |
| 24368195 | Prepare LCW for SHMS DCPS Testing |  | 6d | 2014-01-10 | 2014-01-17 | 24368020, 24368190a FS-13d, 24368190 FS-13d |  |  |  |  | 263d | 2d | 8/5 M-F w/JLAB Holidays ReBaseline | SUPPLIES & MATERIALS; MECH TECH [40 h] | 7,386.73 |  | 24368210 | 5 |  |  |  |  | 0 |  | FENKER H | 1 | 1 |  | H | HOWARD F |  |  | 09-022 | 10-069 |  | 11-046 | 12-012 | 12-036F |  | 13-006 |  | PE | PE | 13-015 | PR |  | 14-001 |  |  | 11-026 |  |  |  |  |  |  |  |  |  |  | Pat | 12-003 |  |  |  |  |  |  |  |
| 24368200 | Prepare AC Power for SHMS DCPS Testing |  | 6d | 2014-01-10 | 2014-01-17 | 24368020 |  |  |  |  | 263d | 2d | 8/5 M-F w/JLAB Holidays ReBaseline | ELEC ENG [80 h]; SUPPLIES & MATERIALS | 16,998.26 |  | 24368215 | 5 |  |  |  |  | 0 |  | FENKER H | 1 | 1 |  | S | HOWARD F |  | ST | 09-022 | 10-069 |  | 11-046 | 12-012 | 12-036F |  | 13-006F |  | PE | PE | 13-015 | PR |  | 14-001 |  |  | 11-026 |  |  |  |  |  |  |  |  |  |  | Pat | 12-003 |  |  |  |  |  |  |  |
| 24368030 | Cool Down HMS Q2 |  | 10d | 2014-01-21 | 2014-02-03 | 24368025 |  |  |  |  | 251d | 0d | 8/5 M-F w/JLAB Holidays ReBaseline |  |  |  | 24368195 | 0 |  |  |  |  | 0 |  | FENKER H | 1 | 1 |  | Z | HOWARD F |  |  | 09-022 | 10-069 |  | 11-046 | 12-012 | 12-036F |  | 13-006F |  |  |  | 13-015 | PR |  |  |  | NO RESOURCES | 11-026 |  |  |  |  |  |  |  |  |  |  | Pat | 12-003 |  |  |  |  |  |  |  |
| 24368205 | Connect HMS Q1 to SHMS DCPS #1 |  | 2d | 2014-01-21 | 2014-01-22 | 24368025 |  |  |  |  | 261d | 0d | 8/5 M-F w/JLAB Holidays ReBaseline | ELEC TECH [32 h] | 1,503.68 |  | 24368220 | 5 |  |  |  |  | 0 |  | FENKER H | 1 | 1 |  | H | HOWARD F |  |  | 09-022 | 10-069 |  | 11-046 | 12-012 | 12-036F |  | 13-006F |  | PE |  | 13-015 | PR |  | 14-001 |  |  | 11-026 |  |  |  |  |  |  |  |  |  |  | Pat | 12-003 |  |  |  |  |  |  |  |
| 24368210 | Test Power Supply DCPS #1 |  | 3d | 2014-01-23 | 2014-01-27 | 24368200, 24368195, 24368205 |  |  |  |  | 261d | 0d | 8/5 M-F w/JLAB Holidays ReBaseline | MECH ENG [48 h] | 3,584.16 |  | 24368225 | 5 |  |  |  |  | 0 |  | FENKER H | 1 | 1 |  | H | HOWARD F |  |  | 09-022 | 10-069 |  | 11-046 | 12-012 | 12-036F |  | 13-006F |  | PE | PE | 13-015 | PR |  | 14-001 |  |  | 11-026 |  |  |  |  |  |  |  |  |  |  | Pat | 12-003 |  |  |  |  |  |  |  |
| 24368500 | Install Beam Line upstream of Target (6GeV) |  | 1d | 2014-01-23 | 2014-01-23 | 24368495 |  |  |  |  | 537d | 499d | 8/5 M-F w/JLAB Holidays ReBaseline |  |  |  | 24368437 | 8 |  |  |  |  | 0 |  | FENKER H | 1 | 1 |  | Z | HOWARD F |  |  |  | 10-069 |  | 11-046 | 12-012 |  | 12-054 | 13-006 |  | PE |  | 13-015 | PR |  |  |  |  |  |  |  |  |  |  |  |  |  |  |  |  |  |  |  |  |  |  |  |  |
| 24368215 | Connect HMS Q1 to SHMS DCPS #2 |  | 2d | 2014-01-28 | 2014-01-29 | 24368210 |  |  |  |  | 261d | 0d | 8/5 M-F w/JLAB Holidays ReBaseline | ELEC TECH [32 h] | 1,503.68 |  | 24368230 | 5 |  |  |  |  | 0 |  | FENKER H | 1 | 1 |  | H | HOWARD F |  |  | 09-022 | 10-069 |  | 11-046 | 12-012 | 12-036F |  | 13-006F |  | PE | PE | 13-015 | PR |  | 14-001 |  |  | 11-026 |  |  |  |  |  |  |  |  |  |  | Pat | 12-003 |  |  |  |  |  |  |  |
| 24368130 | Install Fire Protection & Detection Sys of Supprt Struct |  | 21d | 2014-01-30 | 2014-02-27 | 9-140M FS+78d, 24368085M |  |  |  |  | 258d | 16d | 8/5 M-F w/JLAB Holidays ReBaseline | PROCUREMENT>$50K 69; ELEC TECH [160 h]; PLANT ENG [80 h] | 37,172.61 |  | 24368320 | 3 | 23671.01 | 0 | 0 | 100 | 0 |  | FENKER H | 1 | 1 | APP | S | HOWARD F | 08-052 | ST | 09-022 | 10-069 |  | 11-046 | 12-012 | 12-036 | 12-054 | 13-006 | EJ | EJ | EJ | 13-015 | PR |  | 14-001 | 10-076 |  |  |  |  |  |  |  |  |  |  |  |  |  |  |  |  |  |  |  |  |  |
| 24368220 | Test Power Supply DCPS #2 |  | 3d | 2014-01-30 | 2014-02-03 | 24368215 |  |  |  |  | 261d | 10d | 8/5 M-F w/JLAB Holidays ReBaseline | MECH ENG [48 h] | 3,584.16 |  | 24368235 | 5 |  |  |  |  | 0 |  | FENKER H | 1 | 1 |  | H | HOWARD F |  |  | 09-022 | 10-069 |  | 11-046 | 12-012 | 12-036F |  | 13-006F |  | PE |  | 13-015 | PR |  | 14-001 |  |  | 11-026 |  |  |  |  |  |  |  |  |  |  | Pat | 12-003 |  |  |  |  |  |  |  |
| 24368095 | Install Doors in Shield House |  | 5d | 2014-01-31 | 2014-02-06 | 24368090, 24363035, 24363036, 24363037b, 24363037 |  |  |  |  | 189d | 0d | 8/5 M-F w/JLAB Holidays ReBaseline | MECH DES [80 h]; MECH TECH [160 h] | 11,675.2 |  | 24368087 | 2 |  |  |  |  | 0 |  | FENKER H | 1 | 1 |  | S | HOWARD F |  | ST | 09-022 | 10-069 | 11-025 | 11-046 |  | 12-036 | 12-054 | 13-006 |  | EJ |  | 13-015 | PR |  | 14-001 |  |  |  |  |  |  |  |  |  |  |  |  |  |  |  |  |  |  |  |  |  |  |
| 24368122 | Install AC Pwr for Supprt Struct |  | 25d | 2014-01-31 | 2014-03-06 | 9-140M FS+79d, 24368070 FS-18d |  |  |  |  | 253d | 11d | 8/5 M-F w/JLAB Holidays ReBaseline | ELEC ENG [240 h]; SUPPLIES & MATERIALS; PROCUREMENT>$50K 69 | 104,419.99 |  | 24368315 | 3 | 72248.48 | 0 | 0 | 100 | 0 |  | FENKER H | 1 | 1 | APP | S | HOWARD F | 08-052 | ST | 09-022 | 10-069 |  | 11-046 | 12-012 | 12-036 | 12-054 | 13-006 | EJ | EJ | EJ | 13-015 | PR |  | 14-001 | 10-076 |  |  |  |  |  |  |  |  |  |  |  |  |  |  |  |  |  |  |  |  |  |
| 24368140 | Install Cable Tray & Conduits (SHIELD HOUSE) |  | 25d | 2014-01-31 | 2014-03-06 | 24363037, 24368090, 24363036, 24363035 |  |  |  |  | 199d | 0d | 8/5 M-F w/JLAB Holidays ReBaseline | PROCUREMENT<$50K 60; MECH TECH [160 h]; MECH DES [80 h] | 27,871.16 |  | 24368340 | 3 | 16195.96 | 0 | 0 | 100 | 0 |  | FENKER H | 1 | 1 | APP | S | HOWARD F | 08-052 | ST | 09-022 | 10-069 | 11-025 | 11-046 |  | 12-036 | 12-054 | 13-006 | EJ | EJ |  | 13-015 | PR |  | 14-001 |  |  |  |  |  |  |  |  |  | 4362B |  |  |  |  |  |  |  |  |  |  |  |  |
| 24368045 | Procure SHMS Steel Platforms and Stairs (Box O Parts) Part B |  | 22d | 2014-02-03 | 2014-03-04 | 9-140M FS+80d |  |  |  |  | 242d | 0d | 8/5 M-F w/JLAB Holidays ReBaseline | PROCUREMENT>$50K 69 | 88,363.9 |  | 24368383 | 1 | 88363.9 | 0 | 0 | 100 | 0 |  | FENKER H | 1 | 1 |  | D | HOWARD F | 08-052 |  | 09-022 | 10-069 |  | 11-046 | 12-012 | 12-036F |  | 13-006F | EJ |  |  | 13-015 | PR |  | 14-001 |  |  |  |  |  |  |  | 12-022 |  |  |  |  |  |  |  |  |  |  |  |  |  |  |
| 24368035 | Cool Down HMS Q3 |  | 10d | 2014-02-04 | 2014-02-17 | 24368030 |  |  |  |  | 251d | 0d | 8/5 M-F w/JLAB Holidays ReBaseline |  |  |  | 24368200 | 0 |  |  |  |  | 0 |  | FENKER H | 1 | 1 |  | Z | HOWARD F |  |  | 09-022 | 10-069 |  | 11-046 | 12-012 | 12-036F |  | 13-006F |  |  |  | 13-015 | PR |  |  |  | NO RESOURCES | 11-026 |  |  |  |  |  |  |  |  |  |  | Pat | 12-003 |  |  |  |  |  |  |  |
| 24368097 | Establish Alignment Network inside SHMS Shield House |  | 5d | 2014-02-07 | 2014-02-13 | 24368095, 24368075 |  |  |  |  | 189d | 0d | 8/5 M-F w/JLAB Holidays ReBaseline | MECH TECH [80 h] | 3,785.6 |  | 24368482 | 2 |  |  |  |  | 0 |  | FENKER H | 1 | 1 | APP | H | HOWARD F |  |  |  |  |  |  |  |  |  | 13-006 |  | PE |  | 13-015 | PR |  | 14-001 |  |  |  |  |  |  |  |  |  |  |  |  |  |  |  |  |  |  |  |  |  |  |
| 24368100 | Install and Align Detector Frames for DC and Rear Detectors |  | 5d | 2014-02-14 | 2014-02-20 | 24368095, 24368075, 24368097 |  |  |  |  | 189d | 0d | 8/5 M-F w/JLAB Holidays ReBaseline | MECH TECH [176 h]; MECH DES [40 h] | 10,380.32 |  | 24368362 | 2 |  |  |  |  | 0 |  | FENKER H | 1 | 1 | APP | S | HOWARD F |  | ST |  |  |  |  |  |  |  | 13-006 |  | EJ | EJ | 13-015 | PR |  | 14-001 |  |  |  |  |  |  |  |  |  |  |  |  |  |  |  |  |  |  |  |  |  |  |
| 24368505 | Install, Align, Leak-check Upstream Beam-Pipes & Girders (6GEV) |  | 5d | 2014-02-17 | 2014-02-21 | 24351020, 24368495 |  |  |  |  | 458d |  | 8/5 M-F w/JLAB Holidays ReBaseline |  |  |  | 24368438 | 8 |  |  |  |  | 0 |  | FENKER H | 1 | 1 |  | Z | HOWARD F |  |  |  |  |  |  |  |  |  | 13-006 |  | PE |  | 13-015 | PR |  |  |  |  |  |  |  |  |  |  |  |  |  |  |  |  |  |  |  |  |  |  |  |  |
| 24368225 | Connect HMS Dipole to SHMS DCPS #3 |  | 2d | 2014-02-18 | 2014-02-19 | 24368220, 24368035 |  |  |  |  | 251d | 0d | 8/5 M-F w/JLAB Holidays ReBaseline | ELEC TECH [32 h] | 1,503.68 |  | 24368240 | 5 |  |  |  |  | 0 |  | FENKER H | 1 | 1 |  | H | HOWARD F |  |  | 09-022 | 10-069 |  | 11-046 | 12-012 | 12-036F | 12-054 | 13-006F |  | PE |  | 13-015 | PR |  | 14-001 |  |  | 11-026 |  |  |  |  |  |  |  |  |  |  | Pat | 12-003 |  |  |  |  |  |  |  |
| 24368230 | Test Power Supply DCPS #3 |  | 3d | 2014-02-20 | 2014-02-24 | 24368225 |  |  |  |  | 251d | 0d | 8/5 M-F w/JLAB Holidays ReBaseline | MECH ENG [48 h] | 3,584.16 |  | 24368245 | 5 |  |  |  |  | 0 |  | FENKER H | 1 | 1 |  | H | HOWARD F |  |  | 09-022 | 10-069 |  | 11-046 | 12-012 | 12-036F | 12-054 | 13-006F |  | PE |  | 13-015 | PR |  | 14-001 |  |  | 11-026 |  |  |  |  |  |  |  |  |  |  | Pat | 12-003 |  |  |  |  |  |  |  |
| 24368105 | Fab Raised Floor (SHIELD HOUSE) |  | 20d | 2014-02-21 | 2014-03-20 | 24368100, 24368090, 24368097 |  |  |  |  | 189d | 0d | 8/5 M-F w/JLAB Holidays ReBaseline | PROCUREMENT>$50K 69; PROCUREMENT<$50K 60; MECH DES [80 h] | 59,043.26 |  | 24368370 | 2 | 54939.26 | 0 | 0 | 100 | 0 |  | FENKER H | 1 | 1 | APP | D | HOWARD F | 08-052 |  | 09-022 | 10-069 | 11-025 | 11-046 |  | 12-036 | 12-054 | 13-006 | EJ | EJ |  | 13-015 | PR |  | 14-001 |  |  |  |  |  |  |  |  |  |  |  |  |  |  |  |  |  |  |  |  |  |  |
| 24368235 | Connect HMS Dipole to SHMS DCPS #4 |  | 2d | 2014-02-25 | 2014-02-26 | 24368230 |  |  |  |  | 251d | 0d | 8/5 M-F w/JLAB Holidays ReBaseline | ELEC TECH [32 h] | 1,503.68 |  | 24368250 | 5 |  |  |  |  | 0 |  | FENKER H | 1 | 1 |  | H | HOWARD F |  |  | 09-022 | 10-069 |  | 11-046 | 12-012 | 12-036F | 12-054 | 13-006F |  | PE |  | 13-015 | PR |  | 14-001 |  |  | 11-026 |  |  |  |  |  |  |  |  |  |  | Pat | 12-003 |  |  |  |  |  |  |  |
| 24368240 | Test Power Supply DCPS #4 |  | 3d | 2014-02-27 | 2014-03-03 | 24368235 |  |  |  |  | 251d | 0d | 8/5 M-F w/JLAB Holidays ReBaseline | MECH ENG [48 h] | 3,584.16 |  | 24368255 | 5 |  |  |  |  | 0 |  | FENKER H | 1 | 1 |  | H | HOWARD F |  |  | 09-022 | 10-069 |  | 11-046 | 12-012 | 12-036F | 12-054 | 13-006F |  | PE |  | 13-015 | PR |  | 14-001 |  |  | 11-026 |  |  |  |  |  |  |  |  |  |  | Pat | 12-003 |  |  |  |  |  |  |  |
| 24368055 | Install SHMS Steel Platforms and Stairs |  | 15d | 2014-03-03 | 2014-03-21 | 24368045 FS-2d, 24368070, 24368040 FS-2d |  |  |  |  | 242d | 0d | 8/5 M-F w/JLAB Holidays ReBaseline | PROCUREMENT<$50K 60; MECH TECH [240 h]; MECH DES [120 h] | 53,629.3 |  | 24368385 | 1 | 36116.5 | 0 | 0 | 100 | 0 |  | FENKER H | 1 | 1 |  | D | HOWARD F | 08-052 |  | 09-022 | 10-069 |  | 11-046 | 12-012 | 12-036 | 12-054 | 13-006 | EJ | EJ | EJ | 13-015 | PR |  | 14-001 |  |  |  |  |  |  |  | 12-022 |  |  |  |  |  |  |  |  |  |  |  |  |  |  |
| 24368245 | Connect HMS Dipole to SHMS DCPS #5 |  | 2d | 2014-03-04 | 2014-03-05 | 24368240 |  |  |  |  | 251d | 0d | 8/5 M-F w/JLAB Holidays ReBaseline | ELEC TECH [32 h] | 1,503.68 |  | 24368260 | 5 |  |  |  |  | 0 |  | FENKER H | 1 | 1 |  | H | HOWARD F |  |  | 09-022 | 10-069 |  | 11-046 | 12-012 | 12-036F | 12-054 | 13-006F |  | PE |  | 13-015 | PR |  | 14-001 |  |  | 11-026 |  |  |  |  |  |  |  |  |  |  | Pat | 12-003 |  |  |  |  |  |  |  |
| 24368250 | Test Power Supply DCPS #5 |  | 3d | 2014-03-06 | 2014-03-10 | 24368245 |  |  |  |  | 251d | 9d | 8/5 M-F w/JLAB Holidays ReBaseline | MECH ENG [48 h] | 3,584.16 |  | 24368265 | 5 |  |  |  |  | 0 |  | FENKER H | 1 | 1 |  | H | HOWARD F |  |  | 09-022 | 10-069 |  | 11-046 | 12-012 | 12-036F | 12-054 | 13-006F |  | PE |  | 13-015 | PR |  | 14-001 |  |  | 11-026 |  |  |  |  |  |  |  |  |  |  | Pat | 12-003 |  |  |  |  |  |  |  |
| 24368155 | Install Cables & Produce Final Drawings (CABLING) |  | 164d | 2014-03-07 | 2014-10-27 | 24368140, 24366025 FS-122d, 24368085M |  |  |  |  | 203d | 159d | 8/5 M-F w/JLAB Holidays ReBaseline | MECH TECH [1680 h]; MECH DES [160 h]; ELEC ENG [120 h]; SUPPLIES & MATERIALS; MECH ENG [120 h] | 111,723.94 |  | 24368470 | 3 |  |  |  |  | 0 |  | FENKER H | 1 | 1 |  | S | HOWARD F |  | ST |  | 10-069 |  | 11-046 |  | 12-036 | 12-054 | 13-006 |  | PE | PE | 13-015 | PR |  | 14-001 |  |  |  |  |  |  |  |  |  |  |  |  |  |  |  |  |  |  |  |  |  |  |
| 24368265 | Connect Mag Pwr Supplies & instrument Controls |  | 55d | 2014-03-18 | 2014-06-03 | 24368135 FS-34d, 24315037b, 24315036a5 FS-13d, 24342055 |  |  |  |  | 244d | 0d | 8/5 M-F w/JLAB Holidays ReBaseline | ELEC ENG [40 h]; PROCUREMENT<$50K 60; MECH ENG [520 h]; MECH TECH [1000 h] | 94,809.72 |  | 24368110 | 5 | 5656.12 | 0 | 0 | 100 | 0 |  | FENKER H | 1 | 1 | APP | S | HOWARD F |  | ST | 09-022 | 10-069 |  | 11-046 | 12-012 | 12-036 | 12-054 | 13-006 | PE | PE |  | 13-015 | PR |  | 14-001 | 10-076 |  | 11-026 |  |  |  |  |  |  |  |  |  |  |  |  | 11-017 |  |  |  |  |  |  |
| 24368150 | Install Shield House Electrical Pwr (SHIELD HOUSE) |  | 80d | 2014-03-21 | 2014-07-14 | 24368105, 24368140 |  |  |  |  | 189d | 0d | 8/5 M-F w/JLAB Holidays ReBaseline | ELEC ENG [80 h]; PLANT ENG [40 h]; PROCUREMENT<$50K 60; MECH DES [80 h]; MECH ENG [80 h] | 56,228 |  | 24368375 | 3 | 37148.4 | 0 | 0 | 100 | 0 |  | FENKER H | 1 | 1 |  | S | HOWARD F | 08-052 | ST | 09-022 | 10-069 | 11-025 | 11-046 |  | 12-036 | 12-054 | 13-006 | EJ | EJ |  | 13-015 | PR |  | 14-001 |  |  |  |  |  |  |  |  |  |  |  |  |  |  |  |  |  |  |  |  |  |  |
| 24368185 | Construct & Connect Cryogenic Lines |  | 80d | 2014-03-21 | 2014-07-14 | 24364016, 24368070, 24364075, 24364043a, 24368175, 24364065, 24364043, 24368180 |  |  |  |  | 238d | 19d | 8/5 M-F w/JLAB Holidays ReBaseline | MSHOP; MECH DES [200 h]; MECH TECH [2080 h]; MECH ENG [200 h] | 144,257.6 |  | 24368100 | 4 |  |  |  |  | 0 |  | FENKER H | 1 | 1 |  | S | HOWARD F |  | ST | 09-022 | 10-069 |  | 11-046 | 12-012 | 12-036 | 12-054 | 13-006 |  | EJ | EJ | 13-015 | PR |  | 14-001 |  |  | 11-026 |  |  |  |  | 12-022 |  |  |  |  |  |  |  |  |  |  |  |  |  |  |
| 24368135 | Install Mag Pwr Supplies & Utilities on Platform |  | 30d | 2014-03-24 | 2014-05-02 | 24368130, 24368055, 24368115, 24368120, 24368122, 24368250, 24368125 |  |  |  |  | 243d | 0d | 8/5 M-F w/JLAB Holidays ReBaseline | MECH TECH [160 h]; ELEC TECH [160 h]; PROCUREMENT<$50K 60 | 24,084.59 |  | 24368105 | 3 | 8994.99 | 0 | 0 | 100 | 0 |  | FENKER H | 1 | 1 | APP | S | HOWARD F |  | ST | 09-022 | 10-069 | 11-025 | 11-046 | 12-012 | 12-036 | 12-054 | 13-006 | PE | PE |  | 13-015 | PR |  | 14-001 | 10-076 |  | 11-026 |  |  |  |  |  |  |  |  | 09-012 |  |  |  |  | IPL |  |  |  |  |  |
| 24368255 | Pre-Align Magnet Stand Locations |  | 2d | 2014-03-24 | 2014-03-25 | 24368055 |  |  |  |  | 280d | 0d | 8/5 M-F w/JLAB Holidays ReBaseline | MECH TECH [32 h] | 1,514.24 |  | 24368387 | 5 |  |  |  |  | 0 |  | FENKER H | 1 | 1 | APP | H | HOWARD F |  |  | 09-022 | 10-069 | 11-025 | 11-046 |  |  | 12-054 | 13-006 |  | PE |  | 13-015 | PR |  | 14-001 |  |  | 11-026 |  |  |  |  |  |  |  |  |  |  |  |  |  |  |  |  |  |  |  |
| 24368260 | Pre-Align, Install and Assemble Lower Iron Yokes and HB, Q1 Stands |  | 5d | 2014-03-26 | 2014-04-01 | 24368255 |  |  |  |  | 280d |  | 8/5 M-F w/JLAB Holidays ReBaseline | MECH DES [120 h]; MECH ENG [40 h]; MECH TECH [320 h] | 24,285.2 |  | 24368473 | 5 |  |  |  |  | 0 |  | FENKER H | 1 | 1 |  | S | HOWARD F |  | ST | 09-022 | 10-069 |  | 11-046 | 12-012 | 12-036 |  | 13-006 |  | PE |  | 13-015 | PR |  | 14-001 |  |  | 11-026 |  |  |  |  |  |  |  |  |  |  |  |  | 11-017 |  | 07-034 | 08-048 |  |  |  |
| 24368400 | Stack Calorimeter Blocks (SHOWER COUNTER) |  | 40d | 2014-04-02 | 2014-05-28 | 9-140M FS+100d, 24368090, 24325030, 24368060 |  |  |  |  | 279d | 0d | 8/5 M-F w/JLAB Holidays ReBaseline | MECH TECH [320 h] | 15,142.4 |  | 24368390 | 7 |  |  |  |  | 0 |  | FENKER H | 1 | 1 |  | U | HOWARD F |  |  | 09-022 | 10-069 |  | 11-046 |  | 12-036 | 12-054 | 13-006 |  | PE |  | 13-015 | PR |  | 14-001 |  |  |  |  |  |  |  |  |  |  |  | 09-012 |  |  |  |  |  |  |  | 07-024 |  |  |
| 24368475 | Beam-Dump Modifications & Upgrades (6GEV) |  | 30d | 2014-04-02 | 2014-05-13 | 24368060 |  |  |  |  | 401d |  | 8/5 M-F w/JLAB Holidays ReBaseline |  |  |  | 24368030 | 8 |  |  |  |  | 0 |  | FENKER H | 1 | 1 | APP | Z | HOWARD F |  |  | 09-022 | 10-069 | 11-025 | 11-046 |  |  | 12-054 | 13-006 |  | EJ |  | 13-015 | PR |  |  |  |  | 11-026 |  |  |  |  |  |  |  |  |  |  |  |  |  |  |  |  |  |  |  |
| 24368270 | Prep for Review of Hot Check-out & Mag Control systems |  | 30d | 2014-04-22 | 2014-06-03 | 24368265 FS-30d |  |  |  |  | 244d | 0d | 8/5 M-F w/JLAB Holidays ReBaseline | MECH ENG [80 h]; ELEC ENG [120 h] | 14,989.2 |  | 24368130 | 5 |  |  |  |  | 0 |  | FENKER H | 1 | 1 |  | S | HOWARD F |  | ST | 09-022 | 10-069 |  | 11-046 | 12-012 | 12-036 | 12-054 | 13-006 |  | PE |  | 13-015 | PR |  | 14-001 |  |  | 11-026 |  |  |  |  |  |  |  |  |  |  |  |  | 11-017 |  |  |  |  |  |  |
| 24368460 | Install Moeller Quad #2 (6GEV) |  | 1d | 2014-05-13 | 2014-05-13 | 9-140M FS+150d |  |  |  |  | 475d | 0d | 8/5 M-F w/JLAB Holidays ReBaseline |  |  |  | 24368117 | 8 |  |  |  |  | 0 |  | FENKER H | 1 | 1 |  | Z | HOWARD F |  |  |  |  |  |  |  |  |  | 13-006 |  | PE | PE | 13-015 | PR |  |  |  |  |  |  |  |  |  |  |  |  |  |  |  |  |  |  |  |  |  |  |  |  |
| 24368405 | Connect PMTs & Cables (SHOWER COUNTER) |  | 40d | 2014-05-29 | 2014-07-24 | 24325027a, 24368400 |  |  |  |  | 279d | 0d | 8/5 M-F w/JLAB Holidays ReBaseline | ELEC TECH [80 h] | 3,759.2 |  | 24368395 | 7 |  |  |  |  | 0 |  | FENKER H | 1 | 1 |  | H | HOWARD F |  |  | 09-022 | 10-069 |  | 11-046 |  | 12-036 | 12-054 | 13-006 |  | PE |  | 13-015 | PR |  | 14-001 |  |  |  |  |  |  |  |  |  |  |  | 09-012 |  |  |  |  |  |  |  | 07-024 |  |  |
| 24368275M | Comp safety Review of Hot Chkout procedures & Mag control systems | milestone | 0d | 2014-06-03 | 2014-06-03 | 24368270 |  |  |  |  | 244d | 0d | 8/5 M-F w/JLAB Holidays ReBaseline |  |  |  | 24368135M | 5 |  |  |  |  | 0 |  | FENKER H | 1 | 1 |  | Z | HOWARD F |  |  | 09-022 | 10-069 |  | 11-046 | 12-012 | 12-036 | 12-054 | 13-006 |  |  |  | 13-015 | PR |  |  |  |  | 11-026 |  |  |  |  |  | 6 |  |  |  |  |  |  | 11-017 |  |  |  |  |  |  |
| 24368280 | Perform Hot Check-out of Mag Pwr Supplies |  | 108d | 2014-06-04 | 2014-11-04 | 24368275M |  |  |  |  | 244d |  | 8/5 M-F w/JLAB Holidays ReBaseline | MECH ENG [160 h]; ELEC TECH [640 h]; ELEC ENG [160 h] | 54,041.6 |  | 24368140 | 5 |  |  |  |  | 0 |  | FENKER H | 1 | 1 |  | S | HOWARD F |  | ST | 09-022 | 10-069 |  | 11-046 | 12-012 | 12-036 | 12-054 | 13-006 |  | PE |  | 13-015 | PR |  | 14-001 |  |  | 11-026 |  |  |  |  |  |  |  |  |  |  |  |  | 11-017 |  |  |  |  |  |  |
| 24368485 | Connect Additional Quad for Moeller polarimeter |  | 44d | 2014-06-12 | 2014-08-13 | 24368460 FS+20d, 24351030 |  |  |  |  | 475d | 0d | 8/5 M-F w/JLAB Holidays ReBaseline | ELEC TECH [80 h]; MECH TECH [200 h]; PROCUREMENT<$50K 60; ELEC ENG [40 h] | 17,776.25 |  | 24368415 | 8 | 1547.85 | 0 | 0 | 100 | 0 |  | FENKER H | 1 | 1 |  | S | HOWARD F |  | ST |  | 10-069 |  | 11-046 |  |  |  | 13-006 | EJ | PE |  | 13-015 | PR |  | 14-001 |  |  |  |  |  |  |  | 12-022 |  |  |  |  |  |  |  |  |  |  |  |  |  |  |
| 24368160 | Install Fire Protection and Flamm Gas det. (SHIELD HOUSE) |  | 20d | 2014-06-16 | 2014-07-14 | 24368165 FS-20d |  |  |  |  | 189d | 0d | 8/5 M-F w/JLAB Holidays ReBaseline | PROCUREMENT<$50K 60; ELEC TECH [200 h] | 48,995.34 |  | 24368380 | 3 | 39597.34 | 0 | 0 | 100 | 0 |  | FENKER H | 1 | 1 | APP | S | HOWARD F | 08-052 | ST | 09-022 | 10-069 | 11-025 | 11-046 |  | 12-036 | 12-054 | 13-006 | PE | PE |  | 13-015 | PR |  | 14-001 |  |  |  |  |  |  |  |  |  |  |  | 09-012 | 08-016 |  |  |  |  |  |  |  |  |  |
| 24368165 | Install Shield House HVAC (SHIELD HOUSE) |  | 5d | 2014-07-08 | 2014-07-14 | 24368150 FS-5d |  |  |  |  | 189d | 0d | 8/5 M-F w/JLAB Holidays ReBaseline | ELEC TECH [16 h]; MECH TECH [240 h]; PROCUREMENT<$50K 60 | 33,075.82 |  | 24368345 | 3 | 20967.18 | 0 | 0 | 100 | 0 |  | FENKER H | 1 | 1 |  | S | HOWARD F | 08-052 | ST | 09-022 | 10-069 | 11-025 | 11-046 |  | 12-036 | 12-054 | 13-006 | PE | PE |  | 13-015 | PR |  | 14-001 |  |  |  |  |  |  |  |  |  |  |  |  |  |  |  |  |  |  |  |  |  |  |
| 24368415 | Install and Prep Electronics Room DAQ Racks (SHIELD HOUSE) |  | 20d | 2014-07-15 | 2014-08-11 | 24368160 |  |  |  |  | 189d | 0d | 8/5 M-F w/JLAB Holidays ReBaseline | ELEC TECH [80 h]; MECH TECH [160 h]; SUPPLIES & MATERIALS | 16,999.59 |  | 24368350 | 7 |  |  |  |  | 0 |  | FENKER H | 1 | 1 | APP | S | HOWARD F | 08-052 | ST | 09-022 | 10-069 | 11-025 | 11-046 |  | 12-036 | 12-054 | 13-006 | EJ | PE | PE | 13-015 | PR |  | 14-001 |  |  |  |  |  |  |  |  |  |  |  | 09-012 | 08-016 |  |  |  |  |  |  |  |  |  |
| 24368285M | Receive First Mag from vendor | milestone | 0d | 2014-07-16 | 2014-07-16 | 2-27M |  |  |  |  | 207d |  | 8/5 M-F w/JLAB Holidays ReBaseline |  |  |  | 24368035M | 5 |  |  |  |  | 0 |  | FENKER H | 1 | 1 |  | M | HOWARD F |  |  | 09-022 | 10-069 |  | 11-046 | 12-012 | 12-036 |  | 13-006 |  |  |  | 13-015 | PR |  |  |  |  | 11-026 |  |  |  |  |  | 6 |  |  |  |  |  | 12-003 | 11-017 |  |  |  |  | 10-063 | 10-074 |
| 24368290 | Mount Q1 on Supprt Carriage |  | 5d | 2014-07-16 | 2014-07-22 | 24315037b FS+1d, 24312053M, 24315036a5 FS-13d |  |  |  |  | 263d | 13d | 8/5 M-F w/JLAB Holidays ReBaseline | MECH DES [24 h]; MSHOP; PROCUREMENT<$50K 60; MECH TECH [476 h] | 28,915.02 |  | 24368060 | 5 | 5159.5 | 0 | 0 | 100 | 0 |  | FENKER H | 1 | 1 |  | S | HOWARD F |  | ST | 09-022 | 10-069 |  | 11-046 | 12-012 | 12-036 | 12-054 | 13-006 | EJ | PE |  | 13-015 | PR |  | 14-001 |  |  | 11-026 |  |  |  |  |  |  |  |  |  |  |  |  | 11-017 |  |  |  |  |  | 10-074 |
| 24368410 | Test Calorimeter (SHOWER COUNTER) |  | 37d | 2014-07-25 | 2014-09-16 | 24368405 |  |  |  |  | 279d | 253d | 8/5 M-F w/JLAB Holidays ReBaseline | VISTNG USERS [160 h] | 3,294.4 |  | 24368400 | 7 |  |  |  |  | 0 |  | FENKER H | 1 | 1 |  | S | HOWARD F |  | ST | 09-022 | 10-069 |  | 11-046 |  | 12-036 | 12-054 | 13-006 |  | PE |  | 13-015 | PR |  | 14-001 |  |  |  |  |  |  |  |  |  |  |  | 09-012 |  |  |  |  | IPL |  |  | 07-024 |  |  |

Notes:
- 24368070: Steps: Base Pour Complete (done); Lower wall pour complete (done); Upper wall pour complete (done); B4C pour complete; Door, walland roof pours complete; Shield House complete - site clean
- 24368070a: Steps: Base Pour Complete (done); Lower wall pour complete (done); Upper wall pour complete (done); B4C pour complete; Door, walland roof pours complete; Shield House complete - site clean
- 24368070b: Steps: Base Pour Complete (done); Lower wall pour complete (done); Upper wall pour complete (done); B4C pour complete; Door, walland roof pours complete; Shield House complete - site clean
- 24368120: Steps: 0-100
- 24368060: Entry Criteria: Ext Pred: COMPLETE MAGNET CONTRACT
- 24368495: Explanation: Budget contains 4 weeks of Survey & Alignment / Tech in the Mech Tech Budget. 12Aug2010 PMC / Steps: Remove Compton from Beamline; Modify Compton Hardware for new elevation
- 24368455: Explanation: Budget contains 2 weeks of Survey & Alignment Tech in / the Mech Tech Budget. 12Aug2010 PMC / Steps: Magnets placed on beamline; LCW & Power connections to magnets completed
- 24368090: Steps: Install pre-assembled panels in detector room.; Install pre-assembled panels in electronics room.; Lead brick Shield front wall of detector room; Lead Brick Shield front wall of electronics room; Lead Brick Shield beam-side wall of detector room; Assemble/Attach downstream barn door; Fab/Procure Hangers and Brackets
- 24368125: Steps: Install Signal Tray, Duct, Conduit; Install AC Power & HV Tray, Duct, Conduit; Install Auxillary Tray, Duct Conduit
- 24368175: Steps: Modify flex-line support per final Anaconda dimensions; Retrieve flex cryo hoses from storage & inspect; Install flex-line support in the auxilliary target platform
- 24368115: Steps: Procure / Fab Hoses, Pipes, Hangers, Fittings; Prep supply/return connections at pivot; Fab / Install-in-place manifold lines on SHMS; Install valves/fittings on manifolds; Leak-check
- 24368200: Steps: Proc / Install Connectors & Switchgear; Pull & Connect AC Power Cables
- 24368130: Steps: Procure sensors, controllers, interfaces; Install sensors for equipment on SHMS platforms; Connect to Hall-C System
- 24368095: Explanation: Removed 2.0 weeks of MT to keep CR11-046 a Level / 5 / Steps: Motors, Controllers, Wiring, Connectors spec'd. PR's submitted; Motors, Controllers Installed & Tested
- 24368122: Steps: Install AC Pwr for Magnet Power Supplies; Install Convenience Outlets on Support Structure; Install AC Pwr for HVAC; Install Lighting on Platforms; Install AC Pwr for Rotation System
- 24368140: Steps: Install cable tray in electronics room; Install cable tray in detector room; Install tray/laddr for calorimeter
- 24368100: Steps: Install and Align Rear Detectors Frame; Install and Align Drift Chamber Frame
- 24368155: Steps: Pull, Connect, Terminate CH to SHMS signal cables; Pull, Connect, Terminate CH to SHMS HV cables; Pull & Terminate Shower Counter Signal & HV Cables; Pull & Terminate Drift Chamber Ribbon and HV Cables; Pull & Terminate Preshower, Hodoscope, Cerenkov Signal & HV Cables; Install data communication cables; Install Cables for cameras, sensors, threshold, readbacks
- 24368265: Steps: Procure Half-racks, cables, connectors; Pull, Install, and Terminate HB Sensor & Controls Cables; Pull, Install, and Terminate Q1 Sensor & Controls Cables; Pull, Install, and Terminate Q2 Sensor & Controls Cables; Pull, Install, and Terminate Q3 Sensor & Controls Cables; Pull, Install, and Terminate Dipole Sensor & Controls Cables; Connect DCPS AC Pwr & DC Leads; Perform controls check of all DCPS (no DC power out); Verify function of interlocks
- 24368150: Steps: Install Shield-House Lighting; Install Dirty-power circuit; Install Clean-power circuit; Install pump circuit; Install magnet controls circuits
- 24368185: Steps: LN2-Test Refurbished Anaconda; Install cryogas lines from the Hall-C wall to near the pivot; Inspect, leak- and pressure-test flex cryo hoses; Install flex tray, gas lines, Anaconda; Install flex transfer line SHMS end; Install unistrut hangers for cryo gas headers under platform; Install cryo gas headers on unistrut hangers under platform; Fab-in-place unistrut stands for tray to carry L-tubes, DC water-cooled bus, and I&C wiring to magnets 1-2.; Fab-in-place unistrut stands for tray to carry L-tubes, DC water-cooled bus, and I&C wiring to magnets 3-4.; Fab-in-place unistrut stands for tray to carry L-tubes, DC water-cooled bus, and I&C wiring to magnet 5.
- 24368135: Explanation: IPL from 6 GeV 54342045 / Steps: Install & Connect services to HB DCPS; Install & Connect services to Q1 DCPS; Install & Connect services to Q2 DCPS; Install & Connect services to Q3 DCPS; Install & Connect services to Dipole DCPS
- 24368255: Entry Criteria: Ext Pred: COMPLETE MAGNET CONTRACT
- 24368260: Steps: Install HB & Q1 Stands; Install Q2 & Q3 Stands; Install Dipole Stand; Install Lower Q2 Yoke; Install Lower Q3 Yoke; Install Lower Dipole Yoke
- 24368475: Entry Criteria: Ext Pred: COMPLETE MAGNET CONTRACT
- 24368270: Steps: Documentation & Analysis Prepared. TOSP Submitted; Undergo Review
- 24368280: Steps: Checkout HB DCPS; Checkout Q1 DCPS; Checkout Q2 DCPS; Checkout Q3 DCPS; Checkout Dipole DCPS
- 24368485: Steps: Procure/Fab Remaining PWR & LCW Connections; Install & Check PWR & LCW; Power-test Quad
- 24368160: Steps: Procure sensors, controllers, interfaces; Install sensors inside shield house; Connect to Hall-C System
- 24368165: Steps: Procure unit, fans, ductwork; Install unit & connect power, water; Install ducts & fans
- 24368415: Steps: Prep racks w/AC power; Install racks
- 24368285M: Entry Criteria: Ext Pred: COMPLETE MAGNET CONTRACT
- 24368290: Steps: Rig Magnet Into Position; Attach Cryogenics, Power Leads, Controls; Attach to Vacuum System; Survey/Align
- 24368410: Explanation: IPL from 6 GeV 54341020 / Steps: Check Signals from Quadrant-1; Check Signals from Quadrant-2; Check Signals from Quadrant-3; Check Signals from Quadrant-4

| ID | Activity | Type | Duration | Start | Finish | Predecessors | Total float | Free float | Calendar | Resources | Cost | Original Activity ID Rebaseline | Howard's Code | MONTHLY EV COST | RESP - Responsibility | STRT%COMP for CM EVM | FNSH%COMP for CM EVM | EVMS Reporting Codes | CAM RESPONSIBLE | CR 10-069 | CR 11-025 | CR 11-026 | CR 11-046 | CR 12-036 | CR 12-054 | CR 13-006 | BOE Labor | CR 13-015 | Post Rebaseline | CR 14-001 | Remaining Material Cost Based on % Compl | Claimed Material Cost Based on % Complet | Initial Claimed Material Calc | Claimed Material Divider | Advance Purchase Plan > 500K | CR 08-016 | CR 08-052 | Activities with Steps | CR 09-012 | CR 09-022 | BOE Procurement | CR 07-024 | CR 10-074 | CR 11-017 | CR 12-012 | Pat's Code | BOE Expenses | LOE % Pre Calc | LOE % | LOE Divider | LOE Multiplier | Milestone Level | CR 10-076 | CR 07-034 | CR 08-048 | 12 GEV MAJOR PROCUREMENT CATAGORY | CR 10-025 |
| --- | --- | --- | --- | --- | --- | --- | --- | --- | --- | --- | --- | --- | --- | --- | --- | --- | --- | --- | --- | --- | --- | --- | --- | --- | --- | --- | --- | --- | --- | --- | --- | --- | --- | --- | --- | --- | --- | --- | --- | --- | --- | --- | --- | --- | --- | --- | --- | --- | --- | --- | --- | --- | --- | --- | --- | --- | --- |
| 24368145 | Install Drift Gas Manifold |  | 30d | 2014-07-31 | 2014-09-11 | 24324005, 24368140, 24368090 | 282d | 256d | 8/5 M-F w/JLAB Holidays ReBaseline | MECH DES [80 h]; MECH TECH [80 h] | 7,889.6 | 24368093 | 3 | 0 | FENKER H | 1 | 1 | H | HOWARD F | 10-069 | 11-025 | 11-026 | 11-046 | 12-036 | 12-054 | 13-006 | PE | 13-015 | PR | 14-001 |  |  |  |  |  |  |  |  |  |  |  |  |  |  |  |  |  |  |  |  |  |  |  |  |  |  |  |
| 24368570 | Install Rotation Controls of Supprt Struct |  | 20d | 2014-08-12 | 2014-09-09 | 24368415 | 319d |  | 8/5 M-F w/JLAB Holidays ReBaseline | MECH ENG [160 h]; PROCUREMENT>$50K 69; MECH TECH [360 h] | 129,850.63 | 24368305 | 11 | 0 | FENKER H | 1 | 1 | S | HOWARD F | 10-069 |  |  | 11-046 | 12-036 | 12-054 | 13-006 | PE | 13-015 | PR | 14-001 | 100868.23 | 0 | 0 | 100 | APP | 08-016 | 08-052 | ST | 09-012 | 09-022 | PE |  |  |  |  |  |  |  |  |  |  |  |  |  |  |  |  |
| 24368420 | Install Electrnc's (FAST Electrnc's) |  | 115d | 2014-08-15 | 2015-02-09 | 24325027a, 24368415, 24341000a, 2433010 FS-75d, 2433005 FS-75d, 24341000, 24341085, 2433000 FS-75d | 186d | 160d | 8/5 M-F w/JLAB Holidays ReBaseline | ELEC TECH [800 h]; SCIENTIST [400 h] | 67,664 | 24368410 | 7 | 0 | FENKER H | 1 | 1 | S | HOWARD F | 10-069 |  |  | 11-046 | 12-036 | 12-054 | 13-006 | PE | 13-015 | PR | 14-001 |  |  |  |  |  |  |  | ST | 09-012 |  |  | 07-024 |  |  |  |  |  |  |  |  |  |  |  |  |  |  |  |
| 24368295 | Mount HB on Supprt Carriage |  | 5d | 2014-09-23 | 2014-09-29 | 24368290, 28231005, 2-28M | 250d | 0d | 8/5 M-F w/JLAB Holidays ReBaseline | MECH DES [40 h]; MSHOP; PROCUREMENT<$50K 60; MECH TECH [40 h] | 9,104.3 | 24368055 | 5 | 0 | FENKER H | 1 | 1 | S | HOWARD F | 10-069 |  | 11-026 | 11-046 | 12-036 | 12-054 | 13-006 | PE | 13-015 | PR | 14-001 | 5159.5 | 0 | 0 | 100 |  |  |  | ST |  | 09-022 | EJ |  | 10-074 | 11-017 | 12-012 |  |  |  |  |  |  |  |  |  |  |  |  |
| 24368300 | Fiducialize Magnet CL of SHMS Q1 Magnet |  | 1d | 2014-09-23 | 2014-09-23 | 28231010 FS-5d | 274d |  | 8/5 M-F w/JLAB Holidays ReBaseline | MECH TECH [32 h]; MECH DES [8 h] | 1,924.64 | 24368266 | 5 | 0 | FENKER H | 1 | 1 | H | HOWARD F |  |  |  |  |  |  | 13-006 | PE | 13-015 | PR | 14-001 |  |  |  |  |  |  |  |  |  |  |  |  |  |  |  | Pat | PE |  |  |  |  |  |  |  |  |  |  |
| 24368550 | Prep Procurement of SHMS Angle Scribe Plates |  | 20d | 2014-10-01 | 2014-10-28 | 9-155M | 135d | 0d | 8/5 M-F w/JLAB Holidays ReBaseline | MECH DES [160 h] | 8,208 | 24368276 | 11 | 0 | FENKER H | 1 | 1 | H | HOWARD F |  |  |  |  |  |  | 13-006 | EJ | 13-015 | PR | 14-001 |  |  |  |  |  |  |  |  |  |  |  |  |  |  |  | Pat |  |  |  |  |  |  |  |  |  |  |  |
| 24368585LOE | Installation Management P3 |  | 247d | 2014-10-01 | 2015-10-01 | 24368580LOE | 439d | 0d | 8/5 M-F w/JLAB Holidays ReBaseline | SCIENTIST [440 h]; MECH ENG [880 h] | 98,788.8 | 24368290LOE | 90 | 0 | FENKER H | 1 | 1 | E | HOWARD F | 10-069 |  | 11-026 | 11-046 |  |  | 13-006 | PE | 13-015 | PR | 14-001 |  |  |  |  |  |  |  |  |  |  |  |  |  |  |  |  |  | 100 | 0 | 100 | 100 |  |  |  |  |  |  |
| 24368470 | Install Windows & Flanges |  | 30d | 2014-10-29 | 2014-12-11 | 28231000, 24365035, 24365040, 24311077 | 304d |  | 8/5 M-F w/JLAB Holidays ReBaseline | MECH ENG [80 h]; MECH DES [120 h]; MECH TECH [120 h] | 17,808 | 24368450 | 8 | 0 | FENKER H | 1 | 1 | S | HOWARD F | 10-069 |  |  | 11-046 | 12-036 | 12-054 | 13-006 | PE | 13-015 | PR | 14-001 |  |  |  |  |  | 08-016 |  | ST | 09-012 | 09-022 |  |  |  |  | 12-012 |  | PE |  |  |  |  |  |  |  |  |  |  |
| 24368555 | Procure SHMS Angle Scribe Plates |  | 119d | 2014-10-29 | 2015-04-28 | 24368550 | 135d | 0d | 8/5 M-F w/JLAB Holidays ReBaseline | PROCUREMENT<$50K 60 | 41,276 | 24368277 | 11 | 0 | FENKER H | 1 | 1 | D | HOWARD F |  |  |  |  |  |  | 13-006 |  | 13-015 | PR | 14-001 | 41276 | 0 | 0 | 100 |  |  |  |  |  |  | EJ |  |  |  |  | Pat |  |  |  |  |  |  |  |  |  |  |  |
| 24368510 | Install Target Scattering Chamber (6GEV) |  | 5d | 2015-01-08 | 2015-01-14 | 24354022, 24354030b, 9-155M FS+63d | 233d | 0d | 8/5 M-F w/JLAB Holidays ReBaseline |  |  | 24368012 | 9 | 0 | FENKER H | 1 | 1 | Z | HOWARD F |  |  |  |  |  |  | 13-006 |  | 13-015 | PR |  |  |  |  |  |  |  |  |  |  |  |  |  |  |  |  |  |  |  |  |  |  |  |  |  |  |  |  |
| 24368520 | Prep for Vac & pressure systems Safety Review |  | 10d | 2015-01-12 | 2015-01-26 | 9-155M FS+65d | 80d | 0d | 8/5 M-F w/JLAB Holidays ReBaseline | MECH ENG [80 h] | 5,973.6 | 24368115 | 10 | 0 | FENKER H | 1 | 1 | H | HOWARD F | 10-069 |  | 11-026 | 11-046 | 12-036F | 12-054 | 13-006F | PE | 13-015 | PR | 14-001 |  |  |  |  |  |  |  |  |  |  |  |  |  |  | 12-012 |  |  |  |  |  |  |  |  |  |  |  |  |
| 24368515 | Align Target Scattering Chamber (6GEV) |  | 5d | 2015-01-15 | 2015-01-22 | 24368510 | 233d |  | 8/5 M-F w/JLAB Holidays ReBaseline |  |  | 24368013 | 9 | 0 | FENKER H | 1 | 1 | Z | HOWARD F |  |  |  |  |  |  | 13-006 |  | 13-015 | PR |  |  |  |  |  |  |  |  |  |  |  |  |  |  |  |  |  |  |  |  |  |  |  |  |  |  |  |  |
| 24368525M | Comp safety Review of vacuum & pressure Vessel systems Implementn | milestone | 0d | 2015-01-26 | 2015-01-26 | 24368520 | 80d |  | 8/5 M-F w/JLAB Holidays ReBaseline |  |  | 24368120M | 10 | 0 | FENKER H | 1 | 1 | Z | HOWARD F | 10-069 |  | 11-026 | 11-046 | 12-036F | 12-054 | 13-006F |  | 13-015 | PR |  |  |  |  |  |  |  |  |  |  |  |  |  |  |  | 12-012 |  |  |  |  |  |  | 6 |  |  |  |  |  |
| 24368560 | Install & Align SHMS Angle Scribe Plates |  | 10d | 2015-04-29 | 2015-05-12 | 24368555, 24368070b, 24368070 | 135d | 0d | 8/5 M-F w/JLAB Holidays ReBaseline | MECH TECH [240 h] | 11,356.8 | 24368278 | 11 | 0 | FENKER H | 1 | 1 | S | HOWARD F |  |  |  |  |  |  | 13-006 | PE | 13-015 | PR | 14-001 |  |  |  |  |  |  |  | ST |  |  |  |  |  |  |  | Pat |  |  |  |  |  |  |  |  |  |  |  |
| 24368465 | Install Beam Stands (Beam Pipe) |  | 5d | 2015-05-04 | 2015-05-08 | 24368055, 24355025, 24368085M, 24355005, 24355015, 24355010 | 112d | 0d | 8/5 M-F w/JLAB Holidays ReBaseline | MECH ENG [120 h]; MECH DES [360 h] | 27,428.4 | 24368430 | 8 | 0 | FENKER H | 1 | 1 | S | HOWARD F | 10-069 |  |  | 11-046 |  | 12-054 |  | PE | 13-015 | PR | 14-001 |  |  |  |  |  | 08-016 |  | ST | 09-012 |  |  |  |  |  | 12-012 |  | PE |  |  |  |  |  |  |  |  |  |  |
| 24368480 | Install Beam Pipe and Vac Fittings |  | 5d | 2015-05-11 | 2015-05-15 | 24355020, 24355030 FS-5d, 24368465 | 112d | 0d | 8/5 M-F w/JLAB Holidays ReBaseline | SUPPLIES & MATERIALS; MSHOP; MECH TECH [40 h] | 14,749.88 | 24368435 | 8 | 0 | FENKER H | 1 | 1 | S | HOWARD F | 10-069 |  |  | 11-046 |  | 12-054 |  | PE | 13-015 | PR | 14-001 |  |  |  |  |  |  |  | ST |  |  |  |  |  |  | 12-012 |  | PE |  |  |  |  |  |  |  |  |  |  |
| 24368565 | Install SHMS Position Readback System |  | 20d | 2015-05-13 | 2015-06-11 | 24368560, 24368415 | 135d |  | 8/5 M-F w/JLAB Holidays ReBaseline | MECH TECH [120 h]; ELEC TECH [80 h]; SUPPLIES & MATERIALS; PROCUREMENT<$50K 60 | 20,890.44 | 24368300 | 11 | 0 | FENKER H | 1 | 1 | S | HOWARD F | 10-069 |  |  | 11-046 | 12-036 | 12-054 | 13-006 | PE | 13-015 | PR | 14-001 | 10319 | 0 | 0 | 100 |  |  |  | ST |  |  | EJ |  |  |  |  |  | PE |  |  |  |  |  |  |  |  |  |  |
| 24368490 | Leak Test Beam Pipe Vac Sys |  | 5d | 2015-05-18 | 2015-05-22 | 24368480 | 112d |  | 8/5 M-F w/JLAB Holidays ReBaseline | MECH TECH [160 h]; SUPPLIES & MATERIALS; MSHOP | 21,586.92 | 24368440 | 8 | 0 | FENKER H | 1 | 1 | S | HOWARD F | 10-069 |  |  | 11-046 |  | 12-054 | 13-006 | PE | 13-015 | PR | 14-001 |  |  |  |  |  |  |  | ST |  |  |  |  |  |  | 12-012 |  | PE |  |  |  |  |  |  |  |  |  |  |
| 24368305 | Final Assemble & Mount Dipole on Supprt Carriage |  | 20d | 2015-05-19 | 2015-06-17 | 24368260, 24368285M, 24314050M, 24368255, 24368097, 24368100, 24368070 | 0d |  | 8/5 M-F w/JLAB Holidays ReBaseline | MSHOP; PROCUREMENT>$50K 69; PROCUREMENT<$50K 60; MECH DES [80 h]; MECH ENG [40 h]; MECH TECH [1040 h] | 67,138.55 | 24368075 | 5 | 0 | FENKER H | 1 | 1 | S | HOWARD F | 10-069 |  | 11-026 | 11-046 | 12-036 |  | 13-006 | PE | 13-015 | PR | 14-001 | 10834.95 | 0 | 0 | 100 | APP |  |  | ST |  | 09-022 | EJ |  |  | 11-017 | 12-012 |  |  |  |  |  |  |  | 10-076 |  |  |  |  |
| 24368310 | Install & Connect Magnet Insulating Vac system |  | 30d | 2015-05-19 | 2015-07-01 | 24365025, 24365020, 24368525M, 24368305 FS-20d | 0d |  | 8/5 M-F w/JLAB Holidays ReBaseline | PROCUREMENT<$50K 60; MSHOP; MECH TECH [600 h] | 54,189.5 | 24368125 | 5 | 0 | FENKER H | 1 | 1 | S | HOWARD F | 10-069 |  | 11-026 | 11-046 | 12-036 |  | 13-006 | PE | 13-015 | PR | 14-001 | 15478.5 | 0 | 0 | 100 |  |  |  | ST |  | 09-022 | EJ |  |  | 11-017 | 12-012 |  | PE |  |  |  |  |  |  |  |  |  |  |
| 24368315 | Inspect & Assemble Upper Iron Yoke & Stands for Dipole magnet |  | 3d | 2015-06-18 | 2015-06-22 | 24368305 | 7d |  | 8/5 M-F w/JLAB Holidays ReBaseline | MECH TECH [160 h]; MECH ENG [8 h]; MECH DES [8 h] | 8,578.96 | 24368485 | 5 | 0 | FENKER H | 1 | 1 | H | HOWARD F | 10-069 |  | 11-026 | 11-046 | 12-036 |  | 13-006 | EJ | 13-015 | PR | 14-001 |  |  |  |  |  |  |  |  |  |  | EJ |  |  | 11-017 | 12-012 |  | EJ |  |  |  |  |  | 10-076 | 07-034 | 08-048 |  |  |
| 24368425 | Fiducialize SHMS Aerogel Cerenkov Counter (6GEV) |  | 1d | 2015-06-18 | 2015-06-18 | 24368305 | 48d | 4d | 8/5 M-F w/JLAB Holidays ReBaseline |  |  | 24368084 | 7 | 0 | FENKER H | 1 | 1 | Z | HOWARD F |  |  |  |  |  |  | 13-006 | EJ | 13-015 | PR |  |  |  |  |  | APP |  |  |  |  |  |  |  |  |  |  |  |  |  |  |  |  |  |  |  |  | 4362B | 10-025 |
| 24368430 | Fiducialize SHMS Drift Ch's, Hodoscopes, Cerenkovs, Preshower |  | 5d | 2015-06-18 | 2015-06-24 | 24368305 | 44d | 0d | 8/5 M-F w/JLAB Holidays ReBaseline | MECH TECH [160 h]; MECH DES [40 h] | 9,623.2 | 24368082 | 7 | 0 | FENKER H | 1 | 1 | H | HOWARD F |  |  |  |  |  |  | 13-006 | PE | 13-015 | PR | 14-001 |  |  |  |  | APP |  |  |  |  |  |  |  |  |  |  |  |  |  |  |  |  |  |  |  |  | 4362B |  |
| 24368435 | Install Detctr's in Shield House REAR |  | 65d | 2015-06-25 | 2015-09-25 | 24328010ba, 24323005b, 24368090, 24368400, 24368155, 24368095, 24363060, 24368425, 24368430 | 44d | 18d | 8/5 M-F w/JLAB Holidays ReBaseline | PROCUREMENT<$50K 60; ELEC TECH [400 h]; MECH TECH [480 h]; MSHOP | 90,399.9 | 24368120 | 7 | 0 | FENKER H | 1 | 1 | S | HOWARD F | 10-069 | 11-025 | 11-026 | 11-046 | 12-036 | 12-054 | 13-006 | PE | 13-015 | PR | 14-001 | 10319 | 0 | 0 | 100 |  |  |  | ST |  | 09-022 | EJ |  |  |  | 12-012 |  | PE |  |  |  |  |  |  |  |  |  |  |
| 24368325 | Assemble Upper Iron Yoke & Stands for Q2 magnet |  | 3d | 2015-07-16 | 2015-07-20 | 28236005 FS-34d, 24368350 FS-34d, 24368340 FS-27d | 2d |  | 8/5 M-F w/JLAB Holidays ReBaseline | MECH TECH [160 h]; MECH DES [8 h]; MECH ENG [8 h] | 8,578.96 | 24368480 | 5 | 0 | FENKER H | 1 | 1 | H | HOWARD F | 10-069 |  | 11-026 | 11-046 | 12-036 |  | 13-006 | EJ | 13-015 | PR | 14-001 |  |  |  |  |  |  |  |  |  | 09-022 |  |  |  | 11-017 | 12-012 |  |  |  |  |  |  |  |  | 07-034 | 08-048 |  |  |
| 24368340 | Mount Q2 on Supprt Carriage |  | 5d | 2015-07-16 | 2015-07-22 | 2-30M, 24314035 FS-34d, 28236005 FS-34d, 24315037b FS+1d, 24314035a FS-34d, 24368350 FS-34d | 0d |  | 8/5 M-F w/JLAB Holidays ReBaseline | PROCUREMENT<$50K 60; MECH TECH [720 h]; MSHOP | 39,229.9 | 24368065 | 5 | 0 | FENKER H | 1 | 1 | S | HOWARD F | 10-069 |  | 11-026 | 11-046 | 12-036 |  | 13-006 | PE | 13-015 | PR | 14-001 | 5159.5 | 0 | 0 | 100 |  |  |  | ST |  | 09-022 | EJ |  |  | 11-017 | 12-012 |  | EJ |  |  |  |  |  |  |  |  |  |  |
| 24368335M | First New SC Mag Cooled Down in place | milestone | 0d | 2015-08-07 | 2015-08-07 | 28236000, 24368185 | 61d |  | 8/5 M-F w/JLAB Holidays ReBaseline |  |  | 24368145M | 5 | 0 | FENKER H | 1 | 1 | M | HOWARD F | 10-069 |  | 11-026 | 11-046 | 12-036 | 12-054 | 13-006 |  | 13-015 | PR |  |  |  |  |  |  |  |  |  |  | 09-022 |  |  |  |  | 12-012 |  |  |  |  |  |  | 6 |  |  |  |  |  |
| 24368350 | Fiducialize Magnet CL of SHMS Dipole Magnet |  | 3d | 2015-08-26 | 2015-08-28 | 24314035a FS-5d | 2d |  | 8/5 M-F w/JLAB Holidays ReBaseline | MECH DES [24 h]; MECH TECH [96 h] | 5,773.92 | 24368022 | 5 | 0 | FENKER H | 1 | 1 | H | HOWARD F | 10-069 | 11-025 | 11-026 | 11-046 | 12-036F | 12-054 | 13-006 | PE | 13-015 | PR | 14-001 |  |  |  |  | APP | 08-016 |  |  | 09-012 | 09-022 |  |  |  |  | 12-012 |  | PE |  |  |  |  |  |  |  |  |  |  |
| 24368360 | Assemble Upper Iron Yoke & Stands for Q3 magnet |  | 3d | 2015-09-02 | 2015-09-04 | 28236005, 24314035a, 24368370 FS-7d, 24368350 | 3d |  | 8/5 M-F w/JLAB Holidays ReBaseline | MECH TECH [160 h]; MECH DES [8 h]; MECH ENG [8 h] | 8,578.96 | 24368475 | 5 | 0 | FENKER H | 1 | 1 | H | HOWARD F | 10-069 |  | 11-026 | 11-046 | 12-036 |  | 13-006 | EJ | 13-015 | PR | 14-001 |  |  |  |  |  |  |  |  |  | 09-022 | EJ |  |  | 11-017 | 12-012 |  |  |  |  |  |  |  |  | 07-034 | 08-048 |  |  |
| 24368365 | Finucialize Magnet CL of SHMS Q2 Magnet |  | 1d | 2015-09-02 | 2015-09-02 | 28236015 FS-1d | 42d |  | 8/5 M-F w/JLAB Holidays ReBaseline | MECH TECH [32 h]; MECH DES [8 h] | 1,924.64 | 24368492 | 5 | 0 | FENKER H | 1 | 1 | H | HOWARD F |  |  |  |  |  |  | 13-006 | EJ | 13-015 | PR | 14-001 |  |  |  |  |  |  |  |  |  |  |  |  |  |  |  |  |  |  |  |  |  |  |  |  |  | 4313 |  |
| 24368440 | Install Shutter Exit Window |  | 5d | 2015-09-02 | 2015-09-09 | 28236005 | 26d | 0d | 8/5 M-F w/JLAB Holidays ReBaseline | MECH ENG [80 h]; MECH DES [40 h]; MECH TECH [80 h]; ELEC TECH [80 h] | 15,570.4 | 24368455 | 7 | 0 | FENKER H | 1 | 1 | S | HOWARD F | 10-069 |  |  | 11-046 | 12-036 | 12-054 | 13-006 | EJ | 13-015 | PR | 14-001 |  |  |  |  |  | 08-016 |  | ST | 09-012 | 09-022 |  |  |  |  | 12-012 |  | PE |  |  |  |  |  |  |  |  |  |  |
| 24368370 | Mount Q3 on Supprt Carriage |  | 5d | 2015-09-03 | 2015-09-10 | 24368340, 28236010, 2-31M, 24315037b FS+1d | 0d |  | 8/5 M-F w/JLAB Holidays ReBaseline | PROCUREMENT<$50K 60; MSHOP; MECH TECH [720 h] | 39,229.9 | 24368070 | 5 | 0 | FENKER H | 1 | 1 | S | HOWARD F | 10-069 |  | 11-026 | 11-046 | 12-036 |  | 13-006 | PE | 13-015 | PR | 14-001 | 5159.5 | 0 | 0 | 100 |  |  |  | ST |  | 09-022 | EJ |  |  | 11-017 | 12-012 |  | EJ |  |  |  |  |  |  |  |  |  |  |
| 24368445 | Install Detctr's in Shield House FWD |  | 30d | 2015-09-10 | 2015-10-21 | 24323005b, 24363060, 24368155, 24368430, 24321015M, 24368440, 24323012, 24328010ba, 24323025, 24368090, 24368095 | 26d | 0d | 8/5 M-F w/JLAB Holidays ReBaseline | PROCUREMENT<$50K 60; ELEC TECH [400 h]; MECH TECH [480 h]; MSHOP | 90,399.9 | 24368090 | 7 | 0 | FENKER H | 1 | 1 | S | HOWARD F | 10-069 | 11-025 | 11-026 | 11-046 | 12-036 | 12-054 | 13-006 | PE | 13-015 | PR | 14-001 | 10319 | 0 | 0 | 100 |  |  |  | ST |  | 09-022 | EJ |  |  |  | 12-012 |  | EJ |  |  |  |  |  |  |  |  |  |  |
| 24368450 | Hot Check-out of Detctr's in Shield House |  | 40d | 2015-09-28 | 2015-11-20 | 24368420, 24368445 FS-18d, 24368145, 24368435 FS-18d, 24368410 | 26d |  | 8/5 M-F w/JLAB Holidays ReBaseline | ELEC TECH [240 h] | 11,277.6 | 24368160 | 7 | 0 | FENKER H | 1 | 1 | S | HOWARD F | 10-069 | 11-025 | 11-026 | 11-046 | 12-036 | 12-054 | 13-006 | PE | 13-015 | PR | 14-001 |  |  |  |  |  |  |  | ST |  | 09-022 |  |  |  |  | 12-012 |  |  |  |  |  |  |  |  |  |  |  |  |
| 24368590LOE | Installation Management P4 |  | 56d | 2015-10-02 | 2015-12-22 | 24368585LOE | 439d | 501d | 8/5 M-F w/JLAB Holidays ReBaseline | SCIENTIST [84 h]; MECH ENG [200 h] | 21,249.12 | 24368290LOE | 90 | 0 | FENKER H | 1 | 1 | E | HOWARD F | 10-069 |  | 11-026 | 11-046 |  |  | 13-006 | PE | 13-015 | PR | 14-001 |  |  |  |  |  |  |  |  |  |  |  |  |  |  |  |  |  | 100 | 0 | 100 | 100 |  |  |  |  |  |  |
| 24368110 | Install Roof Beams and Wall Blocks in Shield House |  | 1d | 2015-10-22 | 2015-10-22 | 24368435, 24368445 | 42d |  | 8/5 M-F w/JLAB Holidays ReBaseline | MECH TECH [16 h] | 757.12 | 24368090a | 2 | 0 | FENKER H | 1 | 1 | H | HOWARD F | 10-069 | 11-025 | 11-026 | 11-046 | 12-036 | 12-054 | 13-006 | EJ | 13-015 | PR | 14-001 |  |  |  |  |  |  |  |  |  | 09-022 | PE |  |  |  | 12-012 |  |  |  |  |  |  |  |  |  |  |  |  |
| 24368390 | Finucialize Magnet CL of SHMS Q3 Magnet |  | 1d | 2015-11-02 | 2015-11-02 | 28236025 FS-1d | 0d |  | 8/5 M-F w/JLAB Holidays ReBaseline | MECH TECH [32 h]; MECH DES [8 h] | 1,924.64 | 24368502 | 5 | 0 | FENKER H | 1 | 1 | H | HOWARD F | 10-069 |  | 11-026 | 11-046 | 12-036 |  | 13-006 | PE | 13-015 | PR | 14-001 |  |  |  |  |  |  |  |  |  | 09-022 |  |  |  | 11-017 | 12-012 |  |  |  |  |  |  |  |  | 07-034 | 08-048 |  |  |
| 24368530 | Install & Connect Spectrometer Vac system |  | 25d | 2015-11-03 | 2015-12-09 | 24354030b, 24368390, 24354030, 24368490, 28231000, 24368525M, 24365050, 28236025, 24365045, 24365047 | 0d |  | 8/5 M-F w/JLAB Holidays ReBaseline | PROCUREMENT<$50K 60; MECH TECH [600 h]; MSHOP | 54,189.5 | 24368127 | 10 | 0 | FENKER H | 1 | 1 | S | HOWARD F | 10-069 |  | 11-026 | 11-046 | 12-036 | 12-054 | 13-006 | PE | 13-015 | PR | 14-001 | 15478.5 | 0 | 0 | 100 |  |  |  | ST |  | 09-022 | PE |  |  | 11-017 | 12-012 |  | PE |  |  |  |  |  |  |  |  |  |  |
| 24368535 | Install Spool & Bellows for All Magnets |  | 25d | 2015-11-03 | 2015-12-09 | 24368390, 24365030, 24365032, 28231000, 28236025 | 0d |  | 8/5 M-F w/JLAB Holidays ReBaseline | SUPPLIES & MATERIALS; MSHOP; MECH ENG [40 h]; MECH DES [40 h]; MECH TECH [160 h] | 32,406.43 | 24368445 | 10 | 0 | FENKER H | 1 | 1 | S | HOWARD F | 10-069 |  |  | 11-046 | 12-036 |  | 13-006 | PE | 13-015 | PR | 14-001 |  |  |  |  |  |  |  | ST |  | 09-022 |  |  |  |  | 12-012 |  | PE |  |  |  |  |  |  |  |  |  |  |
| 24368540 | Install Slit Controls |  | 10d | 2015-12-10 | 2015-12-23 | 24365050, 24368440 FS-60d, 24368470 FS-60d, 24368535, 24368530 | 0d |  | 8/5 M-F w/JLAB Holidays ReBaseline | MECH TECH [176 h]; MECH ENG [40 h] | 11,315.12 | 24368465 | 10 | 0 | FENKER H | 1 | 1 | S | HOWARD F | 10-069 |  |  | 11-046 | 12-036 | 12-054 | 13-006 | PE | 13-015 | PR | 14-001 |  |  |  |  |  | 08-016 |  | ST | 09-012 | 09-022 |  |  |  |  | 12-012 |  | PE |  |  |  |  |  |  |  |  |  |  |
| 24368545 | Install Sieve Slit Sys |  | 10d | 2015-12-10 | 2015-12-23 | 24368530, 24368535, 24365045, 24365047, 24368470 FS-60d | 0d |  | 8/5 M-F w/JLAB Holidays ReBaseline | MSHOP; MECH ENG [80 h]; MECH TECH [176 h] | 55,120.04 | 24368460 | 10 | 0 | FENKER H | 1 | 1 | S | HOWARD F | 10-069 |  |  | 11-046 | 12-036 | 12-054 | 13-006 | PE | 13-015 | PR | 14-001 |  |  |  |  |  | 08-016 |  | ST | 09-012 | 09-022 |  |  |  |  | 12-012 |  | PE |  |  |  |  |  |  |  |  |  |  |

Notes:
- 24368570: Steps: Delivery of Motors & Drive Components; Delivery of cables, connectors; Delivery of motor controllers and logic; Termination of interconnections; Power & Control Cables Installed. Interlocks Installed.; PLC Programming Complete for Basic Functionality; Initial Rotation Test Completed. Interferences mitigated; Full rotation check completed successfully.; Remotely-controlled Rotation Implemented
- 24368420: Steps: Install Crates and Crate Power; Install Patch Panels; Install Cable Trays; Install Modules; Install Auxiliary Power Supplies & Equipment; Verify Crate & Controller Functions
- 24368295: Steps: Rig Magnet Into Position; assemble yoke; Attach Cryogenics, Power Leads, Controls; Attach to Vacuum System; Survey/Align
- 24368470: Steps: Install upstream window & flange on HB; Prep vacuum flanges HB downstream and Q1 upstream
- 24368560: Steps: Scribe-plate procurement is 24368555; Survey& Attach 20-40 degree plates; Survey& Attach 0-20 degree plates
- 24368465: Steps: Survey downstream beampipe stand locations; Install beampipe stands; Survey/align beampipe stands
- 24368480: Steps: Procure / Fab Remaining Supports and Vacuum Hardware; Install & Connect Downstream Pipe in place
- 24368565: Steps: Delivery of camera, mounts, lighting; Lights & Camera Installed. Video signal run into CH; Stepping-motor readout to computer functional
- 24368490: Steps: Initial Pump-down Downstream Beam Pipe; Repair Leaks Found; Pump-down to acceptable level
- 24368305: Steps: Rig Magnet Into Position; assemble yoke; Assemble & Attach Service Turret; Leak-check Service Turret & Cretify Internal Connectins; Attach Cryogenics, Power Leads, Controls; Attach to Vacuum System; Survey/Align
- 24368310: Steps: Install mounting hardware- does not exist; Install Manifolds- does not exist; Field-fit connections- uses standard off shelf fittings; Fab / Procure / Field-Modify Vacuum Lines- not needed; Blank-off and perform leak-check / repair- ????
- 24368435: Caution: Danger !!! Need 25week duration for this task. / Steps: Rear Detector Supports Installed; S2X & Q2Y Installed; S2X & Q2Y Cableing Complete; HGC Installed; HGC Gas System & Pumps Connected; HGC Cableing Complete
- 24368340: Steps: Rig Magnet Into Position; assemble yoke; Attach Cryogenics, Power Leads, Controls; Attach to Vacuum System; Survey/Align
- 24368440: Steps: Shutter Hardware Installed; Shutter Controls & Interlocks Installed
- 24368370: Steps: Rig Magnet Into Position; assemble yoke; Attach Cryogenics, Power Leads, Controls; Attach Vacuum; Survey/Align
- 24368445: Caution: Danger !!! Need 25week duration for this task. / Steps: Drift Chamber Supports Installed; NGC Supports Installed; Drift Chambers Installed; DC & Cerenkov Gas Lines Pulled; Drift Chamber Gas Manifold Installed; Gas Supplied to Drift Chambers; Drift Chamber Cableing Complete; NGC Installed; NGC Gas Supplied; NGC Cableing Complete
- 24368450: Steps: Drift Chamber signals read-out in DAQ; S1XY signals read-out in DAQ; S2X signals read-out in DAQ; Q2Y signals read-out in DAQ; Preshower signals read-out in DAQ; Shower Counter signals read-out in DAQ; HGC signals read-out in DAQ
- 24368530: Steps: Procure/Fab Interface Vacuum Hardware. Supports, etc.; Install Dipole downstream vacuum plenum & ports; Install HB Upstream Window; Install Vacuum Shutter; Install Spectrometer Vacuum Pump(s), Gauges, Readout
- 24368535: Steps: Procure/Fab/Modify Bellows & Probe supports & hardware; Install HB/Q1 Vacuum Connections; Install Q1/Q2 Vacuum Connections; Install Q2/Q3 Vacuum Connections; Install Q3/Dipole Vacuum Connections; Install Hall and NMR Probes, Cables, Controllers, Readout
- 24368540: Steps: Install cables, controllers, interlocks; Program Basic Functionality of Motion Systems; Slit control data read into CH computer
- 24368545: Steps: Procure/Fab Supports, Interface Components, Motion Controllers; Install pre-HB sieve slit system; Install HB-Q1 Sieve Slits & Collimator

| ID | WBS | Activity | Duration | Start | Finish | Predecessors | Complete | Planned start | Planned finish | Resources | Cost | Actual cost | LOE Divider | LOE Multiplier | Calculated Remaining Total Cost | MONTHLY EV COST | RESP - Responsibility | STRT%COMP for CM EVM | FNSH%COMP for CM EVM | HALL D Related Milestones | CR 07-024 | EVMS Reporting Codes | CAM RESPONSIBLE | CR 08-058 | CR 11-004 | CR 11-006 | CR 11-036 | CR 09-012 | CR 12-054 | CR 11-053 | 12 GeV 2nd level Critical Path | CR 09-014 | CR 09-027 | CR 09-027 Repair | Activities with Steps | CR 10-001 | Remaining Material Cost Based on % Compl | Claimed Material Cost Based on % Complet | Initial Claimed Material Calc | Claimed Material Divider | CR 08-055 | CR 12-055 | CR 10-024 | LOE % Pre Calc | LOE % | 12 GeV 3rd level Critical Path | CR 10-042 | CR 12-021 | Inter Project Link (IPL) | CR 08-016 | CIVIL CRITICAL MILESTONES | CR 10-061 | MARCH!!! | Specification | CR 12-053 |
| --- | --- | --- | --- | --- | --- | --- | --- | --- | --- | --- | --- | --- | --- | --- | --- | --- | --- | --- | --- | --- | --- | --- | --- | --- | --- | --- | --- | --- | --- | --- | --- | --- | --- | --- | --- | --- | --- | --- | --- | --- | --- | --- | --- | --- | --- | --- | --- | --- | --- | --- | --- | --- | --- | --- | --- |
|  | 5 | **1.5 CONSTRUCTION HALL D** |  | 2008-11-06 | 2015-04-01 |  |  |  |  |  |  |  |  |  |  |  |  |  |  |  |  |  |  |  |  |  |  |  |  |  |  |  |  |  |  |  |  |  |  |  |  |  |  |  |  |  |  |  |  |  |  |  |  |  |  |
|  | 1 | **1.5.1 SOLENOID** |  | 2009-01-02 | 2013-10-21 |  |  |  |  |  |  |  |  |  |  |  |  |  |  |  |  |  |  |  |  |  |  |  |  |  |  |  |  |  |  |  |  |  |  |  |  |  |  |  |  |  |  |  |  |  |  |  |  |  |  |
| 151009E |  | FY09 Travel (SOLENOID) | 189d | 2009-01-02 A | 2009-09-30 A | 151009E5 | 100% |  |  | TRAVEL | 919.7 |  | 100 | 100 | 0 | 919.7 | CHUDAKOV | 1 | 1 | D | 07-024 | E | EUGENE C | 08-058 | 11-004 | 11-006 | 11-036 |  |  |  |  |  |  |  |  |  |  |  |  |  |  |  |  |  |  |  |  |  |  |  |  |  |  |  |  |
| 151000 |  | Ship Iron to contractor (SOLENOID) | 6d | 2009-01-05 A | 2009-01-12 A | 9-090M | 100% |  |  |  |  |  |  |  |  | 0 | CHUDAKOV | 1 | 1 | D | 07-024 | Z | EUGENE C |  | 11-004 | 11-006 | 11-036 | 09-012 | 12-054F |  |  |  |  |  |  |  |  |  |  |  |  |  |  |  |  |  |  |  |  |  |  |  |  |  |  |
| 151001 |  | Modify Iron Pole (SOLENOID) | 6d | 2009-01-05 A | 2009-01-12 A | 151000 | 100% |  |  |  |  |  |  |  |  | 0 | CHUDAKOV | 1 | 1 | D | 07-024 | Z | EUGENE C |  | 11-004 | 11-006 | 11-036 | 09-012 | 12-054F |  |  |  |  |  |  |  |  |  |  |  |  |  |  |  |  |  |  |  |  |  |  |  |  |  |  |
| 151002 |  | Ship Iron to Jlab (SOLENOID) | 6d | 2009-01-05 A | 2009-01-12 A | 151001 | 100% |  |  |  |  |  |  |  |  | 0 | CHUDAKOV | 1 | 1 | D | 07-024 | Z | EUGENE C |  | 11-004 | 11-006 | 11-036 | 09-012 | 12-054F |  |  |  |  |  |  |  |  |  |  |  |  |  |  |  |  |  |  |  |  |  |  |  |  |  |  |
| 151015 |  | Dsgn Ring Girders (SOLENOID) | 298d | 2009-03-16 A | 2010-05-24 A | 9-100M FS+60d | 100% |  |  | MECH DES [320 h]; MECH ENG [120 h] | 22,053.32 | 22,053.32 |  |  | 0 | 22378.8 | CHUDAKOV | 1 | 1 | D | 07-024 | H | EUGENE C |  | 11-004 | 11-006 | 11-036 | 09-012 | 12-054F | 11-053 |  |  |  |  |  |  |  |  |  |  |  |  |  |  |  |  |  |  |  |  |  |  |  |  |  |
| 151023 |  | Design Iron Spacers (SOLENOID) | 109d | 2009-03-16 A | 2009-08-17 A | 151020 | 100% |  |  | MECH ENG [40 h]; MECH DES [160 h] | 9,566.8 | 9,566.8 |  |  | 0 | 9872.4 | CHUDAKOV | 1 | 1 | D | 07-024 | H | EUGENE C |  | 11-004 | 11-006 | 11-036 |  | 12-054F | 11-053 |  |  |  |  |  |  |  |  |  |  |  |  |  |  |  |  |  |  |  |  |  |  |  |  |  |
| 151000c |  | Design Test Platform (SOLENOID) | 72d | 2009-06-15 A | 2009-09-24 A | 9-090M FS+162d | 100% |  |  | MECH DES [320 h]; MECH ENG [120 h] | 21,686 | 21,686 |  |  | 0 | 21686 | CHUDAKOV | 1 | 1 | D | 07-024 | H | EUGENE C |  | 11-004 | 11-006 | 11-036 |  |  |  | 2 | 09-014 | 09-027 | 09-027 |  |  |  |  |  |  |  |  |  |  |  |  |  |  |  |  |  |  |  |  |  |
| 151030 |  | Dsgn Missing Mounts (SOLENOID) | 63d | 2009-06-15 A | 2009-09-11 A | 9-100M FS+60d | 100% |  |  | MECH DES [120 h]; MECH ENG [20 h] | 6,537 | 6,537 |  |  | 0 | 6745.8 | CHUDAKOV | 1 | 1 | D | 07-024 | H | EUGENE C |  | 11-004 | 11-006 | 11-036 | 09-012 | 12-054F | 11-053 |  |  |  |  |  |  |  |  |  |  |  |  |  |  |  |  |  |  |  |  |  |  |  |  |  |
| 151000a |  | Labr/Exp to Proc/Assy/Test Rack for Coil Control + 1 Module (SOLENOIID) FY09 | 299d | 2009-07-20 A | 2010-09-29 A | 9-090M FS+162d | 100% |  |  | SUPPLIES & MATERIALS; COMP SCIENT [196.57 h]; ELEC ENG [73.71 h]; ELEC TECH [196.57 h] | 28,081.46 | 25,010.03 |  |  | 0 | 27439.2349 | CHUDAKOV | 1 | 1 | D | 07-024 | S | EUGENE C |  | 11-004 | 11-006 | 11-036 |  |  |  |  |  | 09-027 | 09-027 | ST | 10-001B |  |  |  |  |  |  |  |  |  |  |  |  |  |  |  |  |  |  |  |
| 151000d |  | Design Yoke Baffles (SOLENOID) | 229d | 2009-07-20 A | 2010-06-21 A | 9-090M FS+184d | 100% |  |  | MECH ENG [80 h]; MECH DES [320 h] | 19,606.01 | 19,606.01 |  |  | 0 | 19133.6 | CHUDAKOV | 1 | 1 | D | 07-024 | H | EUGENE C |  | 11-004 | 11-006 | 11-036 |  |  |  | 2 | 09-014 | 09-027 | 09-027 |  |  |  |  |  |  |  |  |  |  |  |  |  |  |  |  |  |  |  |  |  |
| 151000e |  | Write Controls for Solenoid (SOLENOID) | 253d | 2009-07-20 A | 2010-07-26 A | 9-090M FS+162d | 100% |  |  | MECH ENG [320 h] | 20,937.83 | 20,937.83 | 100 | 100 | 0 | 20419.2 | CHUDAKOV | 1 | 1 | D | 07-024 | H | EUGENE C |  | 11-004 | 11-006 | 11-036 |  |  |  | 2 | 09-014 | 09-027 | 09-027 |  |  |  |  |  |  |  |  |  |  |  |  |  |  |  |  |  |  |  |  |  |
| 151000b |  | Procure Rack for Coil Control + 1 Module Set for 1 Coil (SOLENOIID) | 224d | 2009-07-27 A | 2010-06-21 A | 151000aB FS-110d | 100% |  |  | PROCUREMENT<$50K 60 NO ESCALATION FY10 | 125,000 |  |  |  | 0 | 125000 | CHUDAKOV | 1 | 1 | D | 07-024 | S | EUGENE C |  | 11-004 | 11-006 | 11-036 |  |  |  |  |  | 09-027 | 09-027 | ST |  | 0 | 125000 | 12500000 | 100 |  |  |  |  |  |  |  |  |  |  |  |  |  |  |  |
| 151025 |  | Fab Iron Spacers (SOLENOID) | 466d | 2009-09-04 A | 2011-07-25 A | 151023, 9-100M FS+60d | 100% |  |  | MECH ENG [40 h]; PROCUREMENT>$50K 69; PROCUREMENT<$50K 60 | 124,632.06 | 2,666.9 |  |  | 0 | 124599.162525 | CHUDAKOV | 1 | 1 | D | 07-024 | D | EUGENE C |  | 11-004 | 11-006 | 11-036 |  | 12-054F | 11-053 |  |  |  |  |  |  | 0 | 121965.162525 | 12196516.2525 | 100 |  |  |  |  |  |  |  |  |  |  |  |  |  |  |  |
| 151000f |  | Prepare Procurements/Fabrication Packages 2010 (SOLENOID) | 402d | 2009-09-14 A | 2011-04-29 A | 151000c, 151000b FS-5d, 9-100M, 151000e, 151000d | 100% |  |  | MECH DES [560 h]; MECH ENG [200 h] | 38,896.01 | 38,896.01 |  |  | 0 | 38504.4 | CHUDAKOV | 1 | 1 | D | 07-024 | S | EUGENE C |  | 11-004 | 11-006 | 11-036 |  |  |  | 2 | 09-014 | 09-027 | 09-027 | ST |  |  |  |  |  |  |  |  |  |  |  |  |  |  |  |  |  |  |  |  |
| 151033 |  | Fabricate Missing Mounts (SOLENOID) | 51d | 2009-09-14 A | 2009-11-23 A | 151030 | 100% |  |  | PROCUREMENT>$50K 69; MECH ENG [40 h] | 11,403.48 | 2,613.2 |  |  | 0 | 11424.281426 | CHUDAKOV | 1 | 1 | D | 07-024 | H | EUGENE C |  | 11-004 | 11-006 | 11-036 |  | 12-054F | 11-053 |  |  |  |  |  |  | 0 | 8790.281426 | 879028.1426 | 100 |  |  |  |  |  |  |  |  |  |  |  |  |  |  |  |
| 151000aB |  | Labr/Exp to Proc/Assy/Test Rack for Coil Control + 1 Module (SOLENOIID) FY10 | 248d | 2009-09-30 A | 2010-09-29 A | 151000a | 100% |  |  | SUPPLIES & MATERIALS; COMP SCIENT [123.43 h]; ELEC ENG [46.29 h]; ELEC TECH [123.43 h] | 17,777.7 | 15,787.61 |  |  | 0 | 17779.659783 | CHUDAKOV | 1 | 1 | D |  | S | EUGENE C |  | 11-004 | 11-006 | 11-036 |  |  |  |  |  |  |  | ST | 10-001B |  |  |  |  |  |  |  |  |  |  |  |  |  |  |  |  |  |  |  |
| 151010E |  | FY10 Travel (SOLENOID) | 248d | 2009-10-01 A | 2010-09-30 A | 151009E | 100% |  |  | TRAVEL | 1,244.93 |  | 100 | 100 | 0 | 1244.925436 | CHUDAKOV | 1 | 1 | D | 07-024 | E | EUGENE C |  | 11-004 | 11-006 | 11-036 |  |  |  |  |  |  |  |  |  |  |  |  |  |  |  |  |  |  |  |  |  |  |  |  |  |  |  |  |
| 151040 |  | Fab Stands (SOLENOID) | 205d | 2009-10-30 A | 2010-08-30 A | 9-100M FS+60d | 100% |  |  | MECH ENG [40 h]; MECH TECH [40 h]; PROCUREMENT<$50K 60 | 20,612.03 | 4,303.6 |  |  | 0 | 20612.026213 | CHUDAKOV | 1 | 1 | D | 07-024 | H | EUGENE C |  | 11-004 | 11-006 | 11-036 | 09-012 | 12-054F | 11-053 |  |  |  |  |  |  | 0 | 16308.426213 | 1630842.6213 | 100 | 08-055 |  |  |  |  |  |  |  |  |  |  |  |  |  |  |
| 151020 |  | Control Cabling fab (SOLENOID) | 94d | 2010-01-11 A | 2010-05-24 A | 9-100M | 100% |  |  | MECH DES [20 h]; MECH ENG [20 h]; PROCUREMENT<$50K 60; MECH TECH [160 h] | 12,196.55 | 8,900.2 |  |  | 0 | 12196.552955 | CHUDAKOV | 1 | 1 | D | 07-024 | H | EUGENE C |  | 11-004 | 11-006 | 11-036 |  | 12-054F | 11-053 |  |  |  |  |  |  | 0 | 3296.352955 | 329635.2955 | 100 |  |  |  |  |  |  |  |  |  |  |  |  |  |  |  |
| 151000g |  | Evaluate Procurements 2010 (SOLENOID) | 104d | 2010-01-25 A | 2010-06-21 A | 151000f FS-100d | 100% |  |  | MECH ENG [20 h] | 1,317 | 1,317 |  |  | 0 | 1317 | CHUDAKOV | 1 | 1 | D | 07-024 | H | EUGENE C |  | 11-004 | 11-006 | 11-036 |  |  |  | 2 | 09-014 | 09-027 | 09-027 |  |  |  |  |  |  |  |  |  |  |  |  |  |  |  |  |  |  |  |  |  |
| 151000h |  | Track Fabrication 2010 (SOLENOID) | 50d | 2010-04-19 A | 2010-06-28 A | 151000g FS+20d | 100% |  |  | MECH ENG [20 h] | 1,317 | 1,317 |  |  | 0 | 1317 | CHUDAKOV | 1 | 1 | D | 07-024 | H | EUGENE C |  | 11-004 | 11-006 | 11-036 |  |  |  | 2 | 09-014 | 09-027 | 09-027 |  |  |  |  |  |  |  |  |  |  |  |  |  |  |  |  |  |  |  |  |  |
| 151000j |  | Labor for Procurmnt Prep of 3 Module Sets for 3 Coils (SOLENOID) | 91d | 2010-05-24 A | 2010-09-30 A | 9-110M FS+50d, 151000i | 100% |  |  | MECH TECH [20 h] | 834.8 | 834.8 |  |  | 0 | 861.4 | CHUDAKOV | 1 | 1 | D | 07-024 | H | EUGENE C |  | 11-004 | 11-006 | 11-036 |  |  |  | 2 | 09-014 | 09-027 | 09-027 |  |  |  |  |  |  |  |  |  |  |  |  |  |  |  |  |  |  |  |  |  |
| 151000k |  | Procurmnt of 3 Module Sets for 3 Coils / Controls (SOLENOID) Part A | 597d | 2010-05-24 A | 2012-10-15 A | 151000j FS-240d | 100% |  |  | PROCUREMENT>$50K 69; PROCUREMENT<$50K 60 | 120,584 |  |  |  | 0 | 120584 | CHUDAKOV | 1 | 1 | D | 07-024 | D | EUGENE C |  | 11-004 | 11-006 | 11-036 |  |  |  | 2 | 09-014 | 09-027 | 09-027 |  |  | 0 | 120584 | 12058400 | 100 |  | 12-055 |  |  |  |  |  |  |  |  |  |  |  |  |  |
| 151000i |  | Acceptance Checks/Documentation 2010 (SOLENOID) | 72d | 2010-06-21 A | 2010-09-30 A | 151000h FS-47d | 100% |  |  | MECH ENG [40 h]; ELEC ENG [480 h] | 34,443.6 | 34,443.6 |  |  | 0 | 34443.6 | CHUDAKOV | 1 | 1 | D | 07-024 | H | EUGENE C |  | 11-004 | 11-006 | 11-036 |  |  |  | 2 | 09-014 | 09-027 | 09-027 |  |  |  |  |  |  |  |  | 10-024 |  |  |  |  |  |  |  |  |  |  |  |  |
| 151011E |  | FY11 Travel (SOLENOID) | 248d | 2010-10-01 A | 2011-09-30 A | 151010E | 100% |  |  | TRAVEL | 1,285.77 |  | 100 | 100 | 0 | 1285.77 | CHUDAKOV | 1 | 1 | D | 07-024 | E | EUGENE C |  | 11-004 | 11-006 | 11-036 |  |  |  |  |  |  |  |  |  |  |  |  |  |  |  |  | 8.46774193 | 91.53225806 |  |  |  |  |  |  |  |  |  |  |
| 151171 |  | Prepare Procurement Packages for Cladding | 123d | 2011-04-02 A | 2011-09-26 A | 9-110M FS+59d | 100% | 2011-04-04 | 2011-09-26 | MECH DES [20 h]; MECH ENG [12 h] | 1,749 | 1,749 |  |  | 0 | 1749 | CHUDAKOV | 1 | 1 | D | 07-024 | H | EUGENE C |  | 11-004 | 11-006 | 11-036 |  |  | 11-053 |  | 09-014 |  |  |  |  |  |  |  |  |  |  |  |  |  | 3 | 10-042 | 12-021F |  |  |  |  |  |  |  |
| 151050 |  | Move Solenoid to H-D (SOLENOID) | 133d | 2011-04-11 A | 2011-10-17 A | 151025 FS-120d, 151015, 151045 FS-110d, 151020, 16331032, 16331030, 151040, 151002, 151030, 151035 FS-110d, 3P-23M FS-35d | 100% |  |  | PROCUREMENT<$50K 60; MECH TECH [40 h]; MECH ENG [40 h] | 74,652.87 | 4,452.51 |  |  | 0 | 74782.76 | CHUDAKOV | 1 | 1 | D | 07-024 | S | EUGENE C |  | 11-004 | 11-006 | 11-036 | 09-012 | 12-054F | 11-053 |  |  |  |  | ST |  | 0 | 70200.36 | 7020036 | 100 |  |  |  |  |  | 3 | 10-042 |  | IPL | 08-016 |  |  |  |  |  |
| 151035 |  | Fab Ring Girders (SOLENOID) | 77d | 2011-06-01 A | 2011-09-19 A | 151033, 9-100M FS+60d, 151000g FS-5d | 100% |  |  | MECH ENG [20 h]; MECH DES [40 h]; PROCUREMENT<$50K 60 | 47,177.61 | 3,226.2 |  |  | 0 | 47078.00713 | CHUDAKOV | 1 | 1 | D | 07-024 | D | EUGENE C |  | 11-004 | 11-006 | 11-036 | 09-012 | 12-054F | 11-053 |  |  |  |  |  |  | 0 | 43951.40713 | 4395140.713 | 100 |  |  |  |  |  |  |  |  |  |  |  |  |  |  |  |
| 151045 |  | Set Up Solenoid Test Area (SOLENOID) | 76d | 2011-06-30 A | 2011-10-17 A | 2-10M, 2-16M, 9-110M | 100% |  |  | MECH TECH [480 h]; PROCUREMENT<$50K 60; MECH DES [320 h]; MECH ENG [240 h] | 57,828.49 | 52,158.77 |  |  | 0 | 57588.92 | CHUDAKOV | 1 | 1 | D | 07-024 | S | EUGENE C |  | 11-004 | 11-006 | 11-036 | 09-012 | 12-054F | 11-053 |  |  |  |  | ST |  | 0 | 5669.72 | 566972 | 100 |  |  |  |  |  | 3 | 10-042 |  | IPL |  | CVL | 10-061 |  |  |  |
| 151085 |  | Install Yoke mounts (SOLENOID) | 12d | 2011-09-01 A | 2011-09-19 A | 151045 FS-30d | 100% |  |  | MECH DES [12 h]; MECH ENG [40 h]; MECH TECH [200 h] | 11,892.16 | 11,892.16 |  |  | 0 | 12270.84 | CHUDAKOV | 1 | 1 | D | 07-024 | H | EUGENE C |  | 11-004 | 11-006 | 11-036 |  |  |  |  |  |  |  |  |  |  |  |  |  |  |  |  |  |  | 3 | 10-042 |  |  |  |  |  |  |  |  |
| 151147 |  | Safety Review (SOLENOID) | 41d | 2011-09-01 A | 2011-10-28 A | 151045 FS-20d | 100% |  |  | MECH TECH [40 h]; PROCUREMENT>$50K 69; MECH ENG [480 h]; MECH DES [160 h] | 51,818.77 | 42,458.72 |  |  | 0 | 52502.45 | CHUDAKOV | 1 | 1 | D | 07-024 | H | EUGENE C |  | 11-004 | 11-006 | 11-036 |  |  |  |  |  |  |  |  |  | 0 | 9360.05 | 936005 | 100 |  |  |  |  |  | 3 | 10-042 |  |  |  |  |  |  |  |  |
| 151160 |  | Install US Pole (SOLENOID) | 11d | 2011-09-10 A | 2011-09-26 A | 151085 FS-8d, 151060 FS-30d | 100% | 2011-09-12 | 2011-09-26 | MECH TECH [40 h]; MECH DES [12 h]; MECH ENG [16 h]; PROCUREMENT<$50K 60 | 12,730.21 | 3,370.16 |  |  | 0 | 12837.61 | CHUDAKOV | 1 | 1 | D | 07-024 | H | EUGENE C |  | 11-004 | 11-006 | 11-036 |  |  |  |  |  |  |  |  |  | 0 | 9360.05 | 936005 | 100 |  |  |  |  |  | 3 | 10-042 |  |  |  | CVL |  |  |  |  |
| 151090 |  | Install Yoke 1 (SOLENOID) | 6d | 2011-09-12 A | 2011-09-19 A | 151160 | 100% |  |  | MECH ENG [8 h]; MECH DES [12 h]; MECH TECH [16 h]; PROCUREMENT<$50K 60 | 11,152.93 | 1,792.88 |  |  | 0 | 11210.09 | CHUDAKOV | 1 | 1 | D | 07-024 | H | EUGENE C |  | 11-004 | 11-006 | 11-036 |  |  |  |  |  |  |  |  |  | 0 | 9360.05 | 936005 | 100 |  |  |  |  |  | 3 | 10-042 |  |  |  |  |  |  |  |  |
| 151060 |  | Install Solenoid Stands (SOLENOID) | 26d | 2011-09-19 A | 2011-10-24 A | 151045 FS-20d | 100% |  |  | MECH ENG [80 h]; PROCUREMENT>$50K 69; MECH TECH [400 h] | 27,788.08 | 23,108.06 |  |  | 0 | 28065.62 | CHUDAKOV | 1 | 1 | D | 07-024 | H | EUGENE C |  | 11-004 | 11-006 | 11-036 |  |  |  |  |  |  |  |  |  | 0 | 4680.02 | 468002 | 100 |  |  |  |  |  | 3 | 10-042 |  |  |  |  |  |  |  |  |
| 151095 |  | Install Coil 1 (SOLENOID) | 6d | 2011-09-19 A | 2011-09-26 A | 151090 | 100% |  |  | MECH TECH [16 h]; MECH ENG [8 h]; PROCUREMENT<$50K 60 | 10,592.77 | 1,232.72 |  |  | 0 | 10632.05 | CHUDAKOV | 1 | 1 | D | 07-024 | H | EUGENE C |  | 11-004 | 11-006 | 11-036 |  |  |  |  |  |  |  |  |  | 0 | 9360.05 | 936005 | 100 |  |  |  |  |  | 3 | 10-042 |  |  |  |  |  |  |  |  |
| 151100 |  | Install Iron Spacer/Ring Girder 1 (SOLENOID) | 6d | 2011-09-19 A | 2011-09-26 A | 151095 | 100% |  |  | MECH ENG [16 h]; MECH TECH [32 h]; PROCUREMENT<$50K 60 | 11,825.49 | 2,465.44 |  |  | 0 | 11904.05 | CHUDAKOV | 1 | 1 | D | 07-024 | H | EUGENE C |  | 11-004 | 11-006 | 11-036 |  |  |  |  |  |  |  |  |  | 0 | 9360.05 | 936005 | 100 |  |  |  |  |  | 3 | 10-042 |  |  |  |  |  |  |  |  |
| 151105 |  | Install Yoke 2 (SOLENOID) | 2d | 2011-10-10 A | 2011-10-11 A | 151100 FS-10d | 100% |  |  | MECH ENG [8 h]; PROCUREMENT>$50K 69; MECH DES [12 h]; MECH TECH [16 h] | 11,210.09 | 1,850.04 |  |  | 0 | 11210.09 | CHUDAKOV | 1 | 1 | D | 07-024 | H | EUGENE C |  | 11-004 | 11-006 | 11-036 |  |  |  |  |  |  |  |  |  | 0 | 9360.05 | 936005 | 100 |  |  |  |  |  | 3 | 10-042 |  |  |  |  |  |  |  |  |
| 151110 |  | Install Coil 2 (SOLENOID) | 2d | 2011-10-17 A | 2011-10-18 A | 151105 | 100% |  |  | MECH ENG [8 h]; MECH TECH [16 h]; PROCUREMENT>$50K 69 | 10,632.05 | 1,272 |  |  | 0 | 10632.05 | CHUDAKOV | 1 | 1 | D | 07-024 | H | EUGENE C |  | 11-004 | 11-006 | 11-036 |  |  |  |  |  |  |  |  |  | 0 | 9360.05 | 936005 | 100 |  |  |  |  |  | 3 | 10-042 |  |  |  |  |  |  |  |  |
| 151145 |  | Install Iron Spacer/Ring Girder 4 (SOLENOID) | 4d | 2011-10-22 A | 2011-10-27 A | 151140 | 100% | 2011-10-24 | 2011-10-27 | PROCUREMENT>$50K 69; MECH ENG [16 h]; MECH TECH [32 h] | 11,904.05 | 2,544 |  |  | 0 | 11904.05 | CHUDAKOV | 1 | 1 | D | 07-024 | H | EUGENE C |  | 11-004 | 11-006 | 11-036 |  |  |  |  |  |  |  |  |  | 0 | 9360.05 | 936005 | 100 |  |  |  |  |  | 3 | 10-042 |  |  |  |  |  |  |  |  |
| 151115 |  | Install Iron Spacer/Ring Girder 2 (SOLENOID) | 2d | 2011-10-24 A | 2011-10-25 A | 151110 | 100% |  |  | MECH ENG [16 h]; MECH TECH [32 h]; PROCUREMENT>$50K 69 | 11,904.05 | 2,544 |  |  | 0 | 11904.05 | CHUDAKOV | 1 | 1 | D | 07-024 | H | EUGENE C |  | 11-004 | 11-006 | 11-036 |  |  |  |  |  |  |  |  |  | 0 | 9360.05 | 936005 | 100 |  |  |  |  |  | 3 | 10-042 |  |  |  |  |  |  |  |  |
| 151130 |  | Install Iron Spacer/Ring Girder 3 (SOLENOID) | 4d | 2011-10-24 A | 2011-10-27 A | 151125 | 100% |  |  | MECH ENG [16 h]; MECH TECH [32 h]; PROCUREMENT>$50K 69 | 11,904.05 | 2,544 |  |  | 0 | 11904.05 | CHUDAKOV | 1 | 1 | D | 07-024 | H | EUGENE C |  | 11-004 | 11-006 | 11-036 |  |  |  |  |  |  |  |  |  | 0 | 9360.05 | 936005 | 100 |  |  |  |  |  | 3 | 10-042 |  |  |  |  |  |  |  |  |
| 151140 |  | Install Coil 4 (SOLENOID) | 2d | 2011-10-24 A | 2011-10-25 A | 151135 | 100% |  |  | PROCUREMENT>$50K 69; MECH ENG [8 h]; MECH TECH [16 h] | 10,632.05 | 1,272 |  |  | 0 | 10632.05 | CHUDAKOV | 1 | 1 | D | 07-024 | H | EUGENE C |  | 11-004 | 11-006 | 11-036 |  |  |  |  |  |  |  |  |  | 0 | 9360.05 | 936005 | 100 |  |  |  |  |  | 3 | 10-042 |  |  |  |  |  |  |  |  |
| 151120 |  | Install Yoke 3 (SOLENOID) | 2d | 2011-10-25 A | 2011-10-26 A | 151115 | 100% |  |  | MECH TECH [16 h]; MECH DES [12 h]; PROCUREMENT>$50K 69; MECH ENG [8 h] | 11,210.09 | 1,850.04 |  |  | 0 | 11210.09 | CHUDAKOV | 1 | 1 | D | 07-024 | H | EUGENE C |  | 11-004 | 11-006 | 11-036 |  |  |  |  |  |  |  |  |  | 0 | 9360.05 | 936005 | 100 |  |  |  |  |  | 3 | 10-042 |  |  |  |  |  |  |  |  |
| 151125 |  | Install Coil 3 (SOLENOID) | 3d | 2011-10-25 A | 2011-10-27 A | 151120 | 100% |  |  | PROCUREMENT>$50K 69; MECH ENG [8 h]; MECH TECH [16 h] | 10,632.05 | 1,272 |  |  | 0 | 10632.05 | CHUDAKOV | 1 | 1 | D | 07-024 | H | EUGENE C |  | 11-004 | 11-006 | 11-036 |  |  |  |  |  |  |  |  |  | 0 | 9360.05 | 936005 | 100 |  |  |  |  |  | 3 | 10-042 |  |  |  |  |  |  |  |  |
| 151170 |  | Install DS Pole (SOLENOID) | 3d | 2011-10-26 A | 2011-10-28 A | 151145, 151147 | 100% |  |  | MECH TECH [40 h]; PROCUREMENT<$50K 60; MECH ENG [16 h]; MECH DES [12 h] | 12,837.61 | 3,477.56 |  |  | 0 | 12837.61 | CHUDAKOV | 1 | 1 | D | 07-024 | H | EUGENE C |  | 11-004 | 11-006 | 11-036 |  |  |  |  | 09-014 |  |  |  |  | 0 | 9360.05 | 936005 | 100 |  |  |  |  |  | 3 | 10-042 |  |  |  |  |  |  |  |  |
| 151135 |  | Install Yoke 4 (SOLENOID) | 2d | 2011-10-27 A | 2011-10-29 A | 151130 | 100% | 2011-10-27 | 2011-10-28 | MECH TECH [16 h]; MECH DES [12 h]; MECH ENG [8 h]; PROCUREMENT>$50K 69 | 11,210.09 | 1,850.04 |  |  | 0 | 11210.09 | CHUDAKOV | 1 | 1 | D | 07-024 | H | EUGENE C |  | 11-004 | 11-006 | 11-036 |  |  |  |  |  |  |  |  |  | 0 | 9360.05 | 936005 | 100 |  |  |  |  |  | 3 | 10-042 |  |  |  |  |  |  |  |  |
| 151150 |  | Elect Test Coils (SOLENOID) | 6d | 2011-11-14 A | 2011-11-21 A | 151000ka FS-150d, 151000k FS-150d, 151170, 151147 | 100% |  |  | MECH ENG [8 h]; MECH TECH [120 h]; PROCUREMENT<$50K 60 | 7,063.77 | 5,893.76 |  |  | 0 | 7063.77 | CHUDAKOV | 1 | 1 | D | 07-024 | H | EUGENE C |  | 11-004 | 11-006 | 11-036 | 09-012 |  |  |  |  |  |  |  |  | 0 | 1170.01 | 117001 | 100 |  |  |  |  |  | 3 | 10-042 |  |  |  |  |  |  |  |  |
| 151155 |  | Leak Test Coils (SOLENOID) | 52d | 2011-11-21 A | 2012-02-13 A | 151150 FS-100d | 100% |  |  | MECH TECH [200 h]; MECH ENG [8 h]; PROCUREMENT<$50K 60 | 10,618.97 | 9,448.96 |  |  | 0 | 10618.97 | CHUDAKOV | 1 | 1 | D | 07-024 | H | EUGENE C |  | 11-004 | 11-006 | 11-036 |  |  |  |  |  |  |  |  |  | 0 | 1170.01 | 117001 | 100 |  |  |  |  |  | 3 | 10-042 |  |  |  | CVL |  |  |  |  |
| 151070 |  | Install DC Buswork (SOLENOID) | 257d | 2011-12-19 A | 2013-01-07 A | 151050, 151055 FS-60d, 151065 FS-80d | 100% |  |  | PROCUREMENT>$50K 69; MECH TECH [320 h]; MECH ENG [40 h]; MECH DES [40 h] | 42,500.96 | 19,100.85 |  |  | 0 | 42352.51 | CHUDAKOV | 1 | 1 | D | 07-024 | H | EUGENE C |  | 11-004 | 11-006 | 11-036 |  | 12-054F | 11-053 |  |  |  |  |  |  | 0 | 23400.11 | 2340011 | 100 |  |  |  |  |  | 3 | 10-042 |  |  |  |  |  | XX |  |  |
| 151171a |  | Procure Cladding | 102d | 2012-01-16 A | 2012-06-11 A | 151171 FS+10d, 9-120M FS+41d | 100% | 2012-01-17 | 2012-06-11 | PROCUREMENT<$50K 60; PROCUREMENT>$50K 69 | 103,190 |  |  |  | 0 | 103190 | CHUDAKOV | 1 | 1 | D | 07-024 | D | EUGENE C |  | 11-004 | 11-006 | 11-036 |  |  | 11-053 |  | 09-014 |  |  |  |  | 0 | 103190 | 10319000 | 100 |  |  |  |  |  | 3 | 10-042 | 12-021F |  |  |  |  |  |  |  |
| 151173 |  | Develop cryo/magnet elect/pipe interface | 160d | 2012-02-01 A | 2012-09-17 A | 9-120M FS+80d | 100% |  |  | MECH DES [170 h]; MECH ENG [170 h] | 20,109.3 | 20,109.3 |  |  | 0 | 20109.3 | CHUDAKOV | 1 | 1 | D |  | H | EUGENE C |  |  |  |  |  |  |  |  |  |  |  |  |  |  |  |  |  |  |  |  |  |  | 3 |  | 12-021 |  |  |  |  |  |  |  |
| 151173a |  | Procure elec/piping interface hardware Part A | 180d | 2012-02-01 A | 2012-10-15 A | 151173 FS-70d | 100% |  |  | PROCUREMENT<$50K 60; PROCUREMENT>$50K 69 | 52,000 |  |  |  | 0 | 52000 | CHUDAKOV | 1 | 1 | D |  | D | EUGENE C |  |  |  |  |  |  |  |  |  |  |  |  |  | 0 | 52000 | 5200000 | 100 |  | 12-055 |  |  |  | 3 |  | 12-021 |  |  |  |  |  |  |  |
| 151173c |  | Develop solenoid vacuum manifold | 116d | 2012-02-01 A | 2012-07-16 A | 9-120M FS+81d | 100% |  |  | MECH DES [170 h]; MECH ENG [102 h] | 15,341.14 | 15,341.14 |  |  | 0 | 15341.14 | CHUDAKOV | 1 | 1 | D |  | H | EUGENE C |  |  |  |  |  |  |  |  |  |  |  |  |  |  |  |  |  |  |  |  |  |  | 3 |  | 12-021 |  |  |  |  |  |  |  |
| 151173g |  | FMEA for solenoid | 136d | 2012-02-01 A | 2012-08-13 A | 9-120M FS+81d | 100% |  |  | MECH ENG [340 h] | 23,840.8 | 23,840.8 |  |  | 0 | 23840.8 | CHUDAKOV | 1 | 1 | D |  | H | EUGENE C |  |  |  |  |  |  |  |  |  |  |  |  |  |  |  |  |  |  |  |  |  |  | 3 |  | 12-021 |  |  |  |  |  |  |  |
| 151173j |  | Develop shims and baffle support | 33d | 2012-02-01 A | 2012-03-19 A | 9-120M FS+80d | 100% |  |  | MECH DES [34.08 h]; MECH ENG [51.12 h] | 5,226.16 | 5,226.16 |  |  | 0 | 5226.168 | CHUDAKOV | 1 | 1 | D |  | H | EUGENE C |  |  |  |  |  |  |  |  |  |  |  |  |  |  |  |  |  |  |  |  |  |  | 3 |  | 12-021 |  |  |  |  |  |  |  |
| 151173k |  | Procure shims and baffle support | 58d | 2012-03-01 A | 2012-05-21 A | 151173j FS-35d | 100% |  |  | PROCUREMENT<$50K 60 | 12,000 |  |  |  | 0 | 12000 | CHUDAKOV | 1 | 1 | D |  | D | EUGENE C |  |  |  |  |  |  |  |  |  |  |  |  |  | 0 | 12000 | 1200000 | 100 |  |  |  |  |  | 3 |  | 12-021 |  |  |  |  |  |  |  |
| 151055 |  | Install DC Sys (SOLENOID) | 138d | 2012-03-03 A | 2012-09-17 A | 151045 FS+110d | 100% | 2012-03-05 | 2012-09-17 | MECH TECH [320 h]; PROCUREMENT>$50K 69; MECH ENG [40 h] | 22,875.64 | 17,025.6 |  |  | 0 | 22875.64 | CHUDAKOV | 1 | 1 | D | 07-024 | H | EUGENE C |  | 11-004 | 11-006 | 11-036 | 09-012 | 12-054F | 11-053 |  |  |  |  |  |  | 0 | 5850.04 | 585004 | 100 |  |  |  |  |  | 3 | 10-042 |  |  |  |  |  |  | 151055 |  |
| 151173n |  | Install shims and baffle support | 46d | 2012-03-19 A | 2012-05-21 A | 151173k FS-45d | 100% |  |  | MECH TECH [272 h] | 12,087.68 | 12,087.68 |  |  | 0 | 12087.68 | CHUDAKOV | 1 | 1 | D |  | H | EUGENE C |  |  |  |  |  |  |  |  |  |  |  |  |  |  |  |  |  |  |  |  |  |  | 3 |  | 12-021 |  |  |  |  |  | 151173n |  |
| 151065 |  | Install Solenoid Controls (SOLENOID) | 165d | 2012-05-07 A | 2012-12-17 A | 151045 FS+47d, 9-120M FS+163d | 100% | 2012-05-07 | 2013-01-07 | MECH ENG [80 h]; MECH TECH [320 h]; PROCUREMENT<$50K 60 | 23,582.33 | 20,049.72 |  |  | 0 | 23340.41 | CHUDAKOV | 1 | 1 | D | 07-024 | H | EUGENE C |  | 11-004 | 11-006 | 11-036 | 09-012 | 12-054F | 11-053 |  |  |  |  |  |  | 0 | 3510.01 | 351001 | 100 |  |  |  |  |  | 3 | 10-042 |  |  |  |  |  |  | 151065 |  |
| 151080 |  | Install Controls Cabling (SOLENOID) | 55d | 2012-06-05 A | 2012-08-20 A | 151075 FS-40d | 100% |  |  | PROCUREMENT<$50K 60; MECH ENG [80 h]; MECH TECH [880 h]; MECH DES [240 h] | 59,787.61 | 56,277.6 |  |  | 0 | 59787.61 | CHUDAKOV | 1 | 1 | D | 07-024 | H | EUGENE C |  | 11-004 | 11-006 | 11-036 |  | 12-054F | 11-053 |  |  |  |  |  |  | 0 | 3510.01 | 351001 | 100 |  |  |  |  |  | 3 | 10-042 |  |  |  |  |  |  |  |  |
| 151172 |  | Install Cladding (SOLENOID) | 26d | 2012-06-11 A | 2012-07-16 A | 151170, 151171a FS+6d | 100% |  |  | SUPPLIES & MATERIALS; MECH TECH [480 h]; MECH DES [2 h]; MECH ENG [2 h] | 24,567.78 | 21,567.78 |  |  | 0 | 24567.78 | CHUDAKOV | 1 | 1 | D | 07-024 | H | EUGENE C |  | 11-004 | 11-006 | 11-036 |  |  | 11-053 |  | 09-014 |  |  |  |  |  |  |  |  |  |  |  |  |  | 3 | 10-042 | 12-021 |  |  |  |  |  | 151172 |  |
| 151173d |  | Procure solenoid vacuum manifold Part A | 53d | 2012-08-01 A | 2012-10-15 A | 151173c | 100% |  |  | PROCUREMENT<$50K 60 | 27,000 |  |  |  | 0 | 27000 | CHUDAKOV | 1 | 1 | D |  | D | EUGENE C |  |  |  |  |  |  |  |  |  |  |  |  |  | 0 | 27000 | 2700000 | 100 |  | 12-055 |  |  |  | 3 |  | 12-021 |  |  |  |  |  |  |  |
| 151000ka |  | Procurmnt of 3 Module Sets for 3 Coils / Controls (SOLENOID) Part B | 86d | 2012-10-01 A | 2013-01-31 A | 151000j FS-240d | 100% | 2012-10-01 | 2013-02-08 | PROCUREMENT>$50K 69 | 13,000 |  |  |  | 0 | 13000 | CHUDAKOV | 1 | 1 | D | 07-024 | D | EUGENE C |  | 11-004 | 11-006 | 11-036 |  |  |  | 2 | 09-014 | 09-027 | 09-027 |  |  | 0 | 13000 | 1300000 | 100 |  | 12-055 |  |  |  |  |  |  |  |  |  |  | XX |  |  |
| 151173aa |  | Procure elec/piping interface hardware Part B | 54d | 2012-10-01 A | 2012-12-17 A | 151173 FS-70d | 100% |  |  | PROCUREMENT>$50K 69 | 43,000 |  |  |  | 0 | 43000 | CHUDAKOV | 1 | 1 | D |  | D | EUGENE C |  |  |  |  |  |  |  |  |  |  |  |  |  | 0 | 43000 | 4300000 | 100 |  | 12-055 |  |  |  | 3 |  | 12-021 |  |  |  |  |  |  |  |
| 151173d5 |  | Procure solenoid vacuum manifold Part B | 49d | 2012-10-01 A | 2013-02-11 A | 151173c | 100% | 2012-10-01 | 2012-12-10 | PROCUREMENT<$50K 60 | 8,000 |  |  |  | 0 | 8000 | CHUDAKOV | 1 | 1 | D |  | D | EUGENE C |  |  |  |  |  |  |  |  |  |  |  |  |  | 0 | 8000 | 800000 | 100 |  | 12-055 |  |  |  | 3 |  | 12-021 |  |  |  |  | XX |  |  |
| 151175 |  | Connect Coils (SOLENOID) | 26d | 2012-10-15 A | 2012-11-19 A | 151172, 151170, 13321070 | 100% |  |  | MECH DES [40 h]; MECH TECH [320 h]; PROCUREMENT<$50K 60; MECH ENG [40 h] | 20,728.01 | 19,558 |  |  | 0 | 20122.41 | CHUDAKOV | 1 | 1 | D | 07-024 | H | EUGENE C |  | 11-004 | 11-006 | 11-036 |  | 12-054 |  |  | 09-014 |  |  |  |  | 0 | 1170.01 | 117001 | 100 |  |  |  |  |  | 3 | 10-042 |  |  |  |  |  |  | 151175 |  |
| 151173f |  | Install solenoid vacuum manifold | 34d | 2012-11-12 A | 2013-08-30 A | 151173d5 FS-20d, 151173d FS-20d | 100% | 2012-11-12 | 2013-01-08 | MECH TECH [204 h] | 9,355.44 | 9,355.44 |  |  | 4532.88 | 9065.76 | CHUDAKOV | 1 | 1 | D |  | H | EUGENE C |  |  |  |  |  |  |  |  |  |  |  |  |  |  |  |  |  |  |  |  |  |  | 3 |  | 12-021 |  |  |  |  | XX | 151173f |  |
| 151185 |  | Elect Test Solenoid (SOLENOID) | 23d | 2012-11-12 A | 2012-11-19 A | 151175 FS-10d | 100% | 2012-11-12 | 2012-12-14 | MECH DES [97.2 h]; MECH ENG [97.2 h]; MECH TECH [97.2 h] | 16,322.79 | 16,322.79 |  |  | 0 | 15817.356 | CHUDAKOV | 1 | 1 | D | 07-024 | H | EUGENE C |  | 11-004 | 11-006 | 11-036 |  | 12-054 |  |  | 09-014 |  |  |  |  |  |  |  |  |  |  |  |  |  | 3 | 10-042 |  |  |  |  |  |  |  | 12-053 |

Notes:
- 151000a: Steps: Wiring Scheme Markups Complete (done); Develop Initial PLC Programming (done); Assembly and Bench Testing (done); Full Scale Test (done)
- 151000b: Steps: Rack Frames (done); Modules/Terminal Strips (done); Thermocouple Modules (done); Current Source Modules (done); Bench Top Instruments (done); Power Supply Cable (done)
- 151000f: Steps: PR & Supporting Documentation for Iron Spacers Issued (done); PR & Supporting Documentation for Missing Mounts Issued (done); PR & Supporting Documentation for Ring Girders Issued (done); PR & Supporting Documentation for Stands Issued (done)
- 151000aB: Steps: Wiring Scheme Markups Complete (done); Develop Initial PLC Programming (done); Assembly and Bench Testing (done); Full Scale Test (done)
- 151050: Explanation: IPL from 6 GeV 551360 / Steps: Move coils 1 and 4 to Hall D (done); Move coil 3 to Hall D (done); Move Yokes on Hard stand to Hall D (done); Remove lead paint from yokes (done); Repaint yokes (done); Move coil 2 to Hall D (done); Move yoke 1 from TL to Hall D (done); Weld Baffle into yoke 1 (done); Fab new feet for US yoke placement in Hall (done)
- 151045: Explanation: IPL from 6 GeV / 551400LOE / Steps: Install available dison on piers (done); Move upstream yoke to piers (done); Align upstream yoke (done); Set up Nitrogen purge on coils (done); Install dehumidifiers in Hall D (done); Qualify welders for yoke 1/Baffle weld (done); Fab temporary stands for coils (done)

| ID | WBS | Activity | Type | Duration | Start | Finish | Predecessors | Complete | Planned start | Planned finish | Calendar | Resources | Cost | Actual cost | Calculated Remaining Total Cost | MONTHLY EV COST | RESP - Responsibility | STRT%COMP for CM EVM | FNSH%COMP for CM EVM | 12 GeV 3rd level Critical Path | HALL D Related Milestones | CR 07-024 | EVMS Reporting Codes | CAM RESPONSIBLE | CR 10-042 | CR 11-004 | CR 11-006 | CR 11-036 | CR 11-053 | CR 12-054 | MARCH!!! | Remaining Material Cost Based on % Compl | Claimed Material Cost Based on % Complet | Initial Claimed Material Calc | Claimed Material Divider | ReBaseline Actuals Adjustment | Milestone Level | 12 GeV 2nd level Critical Path | CR 09-014 | Original Activity ID Rebaseline | PRIOR MONTH EV COST | Activities with Steps | CR 12-021 | BOE Labor | CR 13-015 | Post Rebaseline | CR 12-040 | CR 13-007 | CR 08-016 | CR 11-026 | CR 12-034 | BOE Procurement | Obligated Prior to Rebaseline | LOE Divider | LOE Multiplier | CR 08-058 | CR 09-027 | CR 09-027 Repair | Advance Purchase Plan > 500K | CR 11-001 | CR 08-035 | CR 09-046 | LOE % Pre Calc | LOE % | CR 10-024 | CR 09-012 | CR 08-052 | CR 12-055 | CR 12-001 | Specification | CR 12-053 |
| --- | --- | --- | --- | --- | --- | --- | --- | --- | --- | --- | --- | --- | --- | --- | --- | --- | --- | --- | --- | --- | --- | --- | --- | --- | --- | --- | --- | --- | --- | --- | --- | --- | --- | --- | --- | --- | --- | --- | --- | --- | --- | --- | --- | --- | --- | --- | --- | --- | --- | --- | --- | --- | --- | --- | --- | --- | --- | --- | --- | --- | --- | --- | --- | --- | --- | --- | --- | --- | --- | --- | --- |
| 151075 |  | Test DC Sys (SOLENOID) |  | 33d | 2012-12-17 A | 2013-03-11 A | 151070 FS-20d | 100% | 2013-01-02 | 2013-02-19 |  | MECH ENG [40 h]; MECH DES [200 h] | 12,836.4 | 12,836.4 | 0 | 12438.8 | CHUDAKOV | 1 | 1 | 3 | D | 07-024 | H | EUGENE C | 10-042 | 11-004 | 11-006 | 11-036 | 11-053 | 12-054F | XX |  |  |  |  |  |  |  |  |  |  |  |  |  |  |  |  |  |  |  |  |  |  |  |  |  |  |  |  |  |  |  |  |  |  |  |  |  |  |  |  |
| 151255 |  | Re-Baseline Actuals Adjustment |  | 1d | 2013-08-30 A | 2013-08-30 A |  | 100% | 2013-09-03 | 2013-09-03 |  | PROCUREMENT>$50K 69 NO ESCALATION | 1,135,844.22 |  |  | 1135844.22 |  |  |  |  |  |  |  |  |  |  |  |  |  |  |  | 0 | 1135844.22 | 113584422 | 100 | ADJ |  |  |  |  |  |  |  |  |  |  |  |  |  |  |  |  |  |  |  |  |  |  |  |  |  |  |  |  |  |  |  |  |  |  |  |
| 151250M |  | Installtn of Solenoid Comptd (SOLENOID) | milestone | 0d | 2013-08-30 A | 2013-08-30 A | 18241040, 18241000, 151011E, 151173f, 151173g, 18241005 | 100% | 2013-09-16 | 2013-09-16 |  |  |  |  |  | 0 | CHUDAKOV | 1 | 1 |  | D |  | M | EUGENE C | 10-042 | 11-004 |  | 11-036 |  |  |  |  |  |  |  |  | 6 | 2 | 09-014 |  |  |  |  |  |  |  |  |  |  |  |  |  |  |  |  |  |  |  |  |  |  |  |  |  |  |  |  |  |  |  |  |
| 251173f |  | Install solenoid vacuum manifold |  | 10d | 2013-09-03 A | 2013-09-16 A | 9-130M FS+228d | 100% | 2013-10-01 | 2013-10-14 | 8/5 M-F w/JLAB Holidays ReBaseline | MECH TECH [86.7 h] | 4,102.64 | 3,976.06 |  | 0 | CHUDAKOV | 1 | 1 | 3 | D |  | S | EUGENE C |  |  |  |  |  |  |  |  |  |  |  |  |  |  |  | 251173f | 3976.062 | ST | 12-021 | PE | 13-015 | PR |  |  |  |  |  |  |  |  |  |  |  |  |  |  |  |  |  |  |  |  |  |  |  |  |  |
| 251195 |  | Repair Solenoid Vac Leaks |  | 4d | 2013-09-03 A | 2013-09-09 A | 9-130M FS+228d | 100% | 2013-10-01 | 2013-10-04 | 8/5 M-F w/JLAB Holidays ReBaseline | MECH TECH [26.94 h]; MECH ENG [9.6 h]; MECH DES [14.08 h]; SR STAFF [6.4 h] | 3,483.92 | 3,376.24 |  | 0 | CHUDAKOV | 1 | 1 | 3 | D | 07-024 | S | EUGENE C | 10-042 | 11-004 | 11-006 | 11-036 |  | 12-054 |  |  |  |  |  |  |  |  | 09-014 | 251195 | 3376.22785 | ST |  | PE | 13-015 | PR | 12-040 | 13-007 |  |  |  |  |  |  |  |  |  |  |  |  |  |  |  |  |  |  |  |  |  |  |  |
| 251666 |  | Consultant Fee (Quench Study WS) |  | 20d | 2013-09-03 A | 2013-10-21 A | 9-130M FS+228d | 100% | 2013-10-01 | 2013-10-28 | 8/5 M-F w/JLAB Holidays ReBaseline | PROCUREMENT<$50K 60 | 6,100 |  |  | 6100 | CHUDAKOV | 1 | 1 |  | D |  | D | EUGENE C |  |  | 11-006 |  |  | 12-054 |  | 0 | 6100 | 610000 | 100 |  |  |  | 09-014 | 25213005 |  |  | 12-021 |  | 13-015 | PR |  | 13-007F | 08-016 | 11-026 | 12-034 | VQ | OB |  |  |  |  |  |  |  |  |  |  |  |  |  |  |  |  |  |  |
| 251250M |  | Installtn of Solenoid Comptd (SOLENOID) | milestone | 0d | 2013-09-09 A | 2013-09-09 A | 251173f | 100% | 2013-10-14 | 2013-10-14 | 8/5 M-F w/JLAB Holidays ReBaseline |  |  |  |  | 0 | CHUDAKOV | 1 | 1 |  | D |  | M | EUGENE C | 10-042 | 11-004 |  | 11-036 |  |  |  |  |  |  |  |  | 6 | 2 | 09-014 | 251250M |  |  |  |  | 13-015 | PR |  | 13-007 |  |  |  |  |  |  |  |  |  |  |  |  |  |  |  |  |  |  |  |  |  |  |  |
|  | 2 | **1.5.2 DETECTORS** |  |  | 2009-01-02 | 2014-04-21 |  |  |  |  |  |  |  |  |  |  |  |  |  |  |  |  |  |  |  |  |  |  |  |  |  |  |  |  |  |  |  |  |  |  |  |  |  |  |  |  |  |  |  |  |  |  |  |  |  |  |  |  |  |  |  |  |  |  |  |  |  |  |  |  |  |
|  | 1 | **1.5.2.1 TRACKING** |  |  | 2009-01-02 | 2014-04-21 |  |  |  |  |  |  |  |  |  |  |  |  |  |  |  |  |  |  |  |  |  |  |  |  |  |  |  |  |  |  |  |  |  |  |  |  |  |  |  |  |  |  |  |  |  |  |  |  |  |  |  |  |  |  |  |  |  |  |  |  |  |  |  |  |  |
|  | 1 | **1.5.2.1.1 FORWARD CHAMBERS** |  |  | 2009-01-02 | 2014-03-31 |  |  |  |  |  |  |  |  |  |  |  |  |  |  |  |  |  |  |  |  |  |  |  |  |  |  |  |  |  |  |  |  |  |  |  |  |  |  |  |  |  |  |  |  |  |  |  |  |  |  |  |  |  |  |  |  |  |  |  |  |  |  |  |  |  |
| 15211009E |  | FY09 Travel (FWD Chambers) |  | 189d | 2009-01-02 A | 2009-09-30 A | 15211009EX | 100% |  |  |  | TRAVEL | 982.69 |  | 0 | 982.69 | CHUDAKOV | 1 | 1 |  | D | 07-024 | E | EUGENE C |  |  | 11-006 |  |  | 12-054F |  |  |  |  |  |  |  |  |  |  |  |  |  |  |  |  |  |  |  | 11-026 |  |  |  | 100 | 100 | 08-058 |  |  |  |  |  |  |  |  |  |  |  |  |  |  |  |
| 15211000a |  | Procurement for Testing the Assembly Proceedure (FWD Chambers) |  | 75d | 2009-06-15 A | 2009-09-29 A | 9-090M FS+162d | 100% |  |  |  | PROCUREMENT<$50K 60 | 22,000 |  | 0 | 22000 | CHUDAKOV | 1 | 1 |  | D | 07-024 | S | EUGENE C |  |  | 11-006 |  |  | 12-054F |  | 0 | 22000 | 2200000 | 100 |  |  | 2 | 09-014 |  |  | ST |  |  |  |  |  |  |  | 11-026 |  |  |  |  |  |  | 09-027 | 09-027 |  |  |  |  |  |  |  |  |  |  |  |  |  |
| 15211000b |  | Testing the Assembly Procedure (FWD Chambers) |  | 131d | 2009-06-15 A | 2009-12-21 A | 9-090M FS+162d, 15211000a FS-106d | 100% | 2009-06-15 | 2009-12-18 |  | MECH ENG [160 h]; MECH TECH [560 h]; ELEC TECH [160 h] | 39,815.12 | 39,815.12 | 0 | 39288.8 | CHUDAKOV | 1 | 1 |  | D | 07-024 | S | EUGENE C |  |  | 11-006 |  |  | 12-054F |  |  |  |  |  |  |  | 2 | 09-014 |  |  | ST |  |  |  |  |  |  |  | 11-026 |  |  |  |  |  |  | 09-027 | 09-027 |  |  |  |  |  |  |  |  |  |  |  |  |  |
| 15211001a |  | Prepare Procurements/Fabrication Packages 2010 (FWD Chambers) |  | 310d | 2009-07-03 A | 2010-09-30 A | 9-090M FS+162d | 100% | 2009-07-06 | 2010-09-30 |  | MECH DES [640 h]; MECH ENG [120 h] | 36,627.44 | 36,627.44 | 0 | 35714.8 | CHUDAKOV | 1 | 1 |  | D | 07-024 | H | EUGENE C |  |  | 11-006 |  |  | 12-054F |  |  |  |  |  |  |  | 2 | 09-014 |  |  |  |  |  |  |  |  |  |  | 11-026 |  |  |  |  |  |  | 09-027 | 09-027 |  |  |  |  |  |  |  |  |  |  |  |  |  |
| 15211002a |  | Engineering Support for Assembly FY10 (FWD Chambers) |  | 290d | 2009-08-03 A | 2010-09-30 A | 15211009E FS+60d | 100% |  |  |  | MECH DES [240 h]; MECH ENG [240 h] | 26,542.03 | 26,542.03 | 0 | 26661.6 | CHUDAKOV | 1 | 1 |  | D | 07-024 | S | EUGENE C |  |  | 11-006 |  |  | 12-054F |  |  |  |  |  |  |  |  |  |  |  | ST |  |  |  |  |  |  |  | 11-026 |  |  |  |  |  |  | 09-027 | 09-027 |  |  |  |  |  |  |  |  |  |  |  |  |  |
| 15211010E |  | FY10 Travel (FWD Chambers) |  | 248d | 2009-10-01 A | 2010-09-30 A | 15211009E | 100% |  |  |  | TRAVEL | 1,330.62 |  | 0 | 1330.624731 | CHUDAKOV | 1 | 1 |  | D | 07-024 | E | EUGENE C |  |  | 11-006 |  |  | 12-054F |  |  |  |  |  |  |  |  |  |  |  |  |  |  |  |  |  |  |  | 11-026 |  |  |  | 100 | 100 |  |  |  |  |  |  |  |  |  |  |  |  |  |  |  |  |
| 15211025 |  | Proc Wire (Field, sense) (FWD Chambers) |  | 38d | 2009-12-21 A | 2010-02-22 A | 9-100M FS+60d, 12321018M | 100% | 2009-12-28 | 2010-02-22 |  | PROCUREMENT<$50K 60 | 14,284.21 |  | 0 | 14284.209897 | CHUDAKOV | 1 | 1 |  | D |  | H | EUGENE C |  |  | 11-006 |  |  | 12-054F |  | 0 | 14284.209897 | 1428420.9897 | 100 |  |  |  | 09-014 |  |  |  |  |  |  |  |  |  |  | 11-026 |  |  |  |  |  |  |  |  | APP |  |  |  |  |  |  |  |  |  |  |  |  |
| 15211030 |  | Proc First Article On-Chamb Electrnc's (capacitors, resistors) (FWD Chambers) |  | 103d | 2009-12-21 A | 2010-05-24 A | 9-100M FS+60d | 100% | 2009-12-28 | 2010-05-24 |  | PROCUREMENT<$50K 60 | 15,932.39 |  | 0 | 15932.39 | CHUDAKOV | 1 | 1 |  | D |  | H | EUGENE C | 10-042 |  | 11-006 |  |  | 12-054F |  | 0 | 15932.39 | 1593239 | 100 |  |  |  |  |  |  |  |  |  |  |  |  |  |  | 11-026 |  |  |  |  |  |  |  |  | APP |  |  |  |  |  |  |  |  |  |  |  |  |
| 15211020 |  | ProcFirst Article PC Boards Cathode Kapton Foil (FWD Chambers) |  | 99d | 2010-01-04 A | 2010-05-24 A | 12321018M, 9-100M FS+60d | 100% |  |  |  | PROCUREMENT<$50K 60 | 44,599.7 |  | 0 | 44599.7 | CHUDAKOV | 1 | 1 |  | D |  | D | EUGENE C | 10-042 |  | 11-006 |  |  | 12-054F |  | 0 | 44599.7 | 4459970 | 100 |  |  |  | 09-014 |  |  |  |  |  |  |  |  |  |  | 11-026 |  |  |  |  |  |  |  |  | APP |  |  |  |  |  |  |  |  |  |  |  |  |
| 15211090 |  | Test Wire (Field, sense) (FWD Chambers) FY10 |  | 37.5d | 2010-02-01 A | 2010-03-25 A | 15211025 | 100% |  |  |  | ELEC TECH [464 h] | 19,232.8 | 19,232.8 | 0 | 19232.8 | CHUDAKOV | 1 | 1 |  | D |  | H | EUGENE C |  |  | 11-006 |  |  | 12-054F |  |  |  |  |  |  |  |  | 09-014 |  |  |  |  |  |  |  |  |  |  | 11-026 |  |  |  |  |  |  |  |  |  | 11-001 |  |  |  |  |  |  |  |  |  |  |  |
| 15211090a |  | Test Wire (Field, sense) (FWD Chambers) FY11 |  | 37.5d | 2010-02-01 A | 2010-03-25 A | 15211090 | 100% |  |  |  | ELEC TECH [124 h] | 5,139.8 | 5,139.8 | 0 | 5298.52 | CHUDAKOV | 1 | 1 |  | D |  | H | EUGENE C |  |  | 11-006 |  |  | 12-054F |  |  |  |  |  |  |  |  | 09-014 |  |  |  |  |  |  |  |  |  |  | 11-026 |  |  |  |  |  |  |  |  |  | 11-001 |  |  |  |  |  |  |  |  |  |  |  |
| 15211100 |  | Fab Setup (FWD Chambers) |  | 238d | 2010-02-01 A | 2011-01-17 A | 15211002a FS-190d, 9-100M FS+60d | 100% | 2010-02-01 | 2011-01-14 |  | MECH TECH [880 h]; MECH ENG [880 h] | 95,541.6 | 95,541.6 | 0 | 94679.2 | CHUDAKOV | 1 | 1 |  | D |  | S | EUGENE C | 10-042 |  | 11-006 |  |  | 12-054F |  |  |  |  |  |  |  |  | 09-014 |  |  | ST |  |  |  |  |  |  |  | 11-026 |  |  |  |  |  |  |  |  |  |  |  |  |  |  |  |  |  |  |  |  |  |
| 15211050 |  | Proc Cables,Connectors (HV, LV, Signal, Gas) (FWD Chambers) |  | 267d | 2010-05-24 A | 2011-06-20 A | 9-110M FS+60d | 100% |  |  |  | PROCUREMENT>$50K 69; PROCUREMENT<$50K 60 | 86,171.57 |  | 0 | 86171.57 | CHUDAKOV | 1 | 1 |  | D |  | D | EUGENE C | 10-042 |  | 11-006 |  |  | 12-054F |  | 0 | 86171.57 | 8617157 | 100 |  |  |  |  |  |  |  |  |  |  |  |  |  |  | 11-026 |  |  |  |  |  |  |  |  | APP |  | 08-035 |  |  |  |  |  |  |  |  |  |  |
| 15211015 |  | Proc PC Boards (G10) (FWD Chambers) |  | 140d | 2010-06-01 A | 2010-12-17 A | 9-100M FS+151d, 12321018M | 100% |  |  |  | PROCUREMENT<$50K 60; PROCUREMENT>$50K 69 | 97,791.89 |  | 0 | 97791.893763 | CHUDAKOV | 1 | 1 |  | D |  | D | EUGENE C | 10-042 |  | 11-006 |  |  | 12-054F |  | 0 | 97791.893763 | 9779189.3763 | 100 |  |  |  | 09-014 |  |  |  |  |  |  |  |  |  |  | 11-026 |  |  |  |  |  |  |  |  | APP |  | 08-035 | 09-046 |  |  |  |  |  |  |  |  |  |
| 15211001c |  | Track Fabrication 2010 (FWD Chambers) |  | 6d | 2010-06-07 A | 2010-06-14 A | 9-100M FS+60d | 100% |  |  |  | MECH ENG [40 h] | 2,634 | 2,634 | 0 | 2634 | CHUDAKOV | 1 | 1 |  | D | 07-024 | H | EUGENE C |  |  | 11-006 |  |  | 12-054F |  |  |  |  |  |  |  | 2 | 09-014 |  |  |  |  |  |  |  |  |  |  | 11-026 |  |  |  |  |  |  | 09-027 | 09-027 |  |  |  |  |  |  |  |  |  |  |  |  |  |
| 15211001b |  | Evaluate Procurements 2010 (FWD Chambers) |  | 72d | 2010-06-21 A | 2010-09-30 A | 15211001a FS+54d, 15211000b | 100% |  |  |  | MECH ENG [40 h] | 2,634 | 2,634 | 0 | 2634 | CHUDAKOV | 1 | 1 |  | D | 07-024 | H | EUGENE C |  |  | 11-006 |  |  | 12-054F |  |  |  |  |  |  |  | 2 | 09-014 |  |  |  |  |  |  |  |  |  |  | 11-026 |  |  |  |  |  |  | 09-027 | 09-027 |  |  |  |  |  |  |  |  |  |  |  |  |  |
| 15211001d |  | Acceptance Checks/Documentation 2010 (FWD Chambers) |  | 53d | 2010-07-19 A | 2010-09-30 A | 9-100M FS+184d | 100% |  |  |  | MECH ENG [40 h] | 2,634 | 2,634 | 0 | 2634 | CHUDAKOV | 1 | 1 |  | D | 07-024 | H | EUGENE C |  |  | 11-006 |  |  | 12-054F |  |  |  |  |  |  |  | 2 | 09-014 |  |  |  |  |  |  |  |  |  |  | 11-026 |  |  |  |  |  |  | 09-027 | 09-027 |  |  |  |  |  |  |  |  |  |  |  |  |  |
| 15211030a |  | Proc Production On-Chamb Electrnc's (capacitors, resistors) (FWD Chambers) |  | 31d | 2010-07-19 A | 2010-08-30 A | 15211030 FS-11d | 100% |  |  |  | PROCUREMENT<$50K 60 NO ESCALATION FY11 | 15,932.39 |  | 0 | 15932.39 | CHUDAKOV | 1 | 1 |  | D |  | D | EUGENE C | 10-042 |  | 11-006 |  |  | 12-054F |  | 0 | 15932.39 | 1593239 | 100 |  |  |  |  |  |  |  |  |  |  |  |  |  |  | 11-026 |  |  |  |  |  |  |  |  | APP |  |  |  |  |  |  |  |  |  |  |  |  |
| 15211080 |  | Test PC Boards (G10) (FWD Chambers) FY10 |  | 101.5d | 2010-07-26 A | 2010-12-17 A | 15211015 | 100% |  |  |  | ELEC TECH [64 h] | 2,697.33 | 2,697.33 | 0 | 2652.8 | CHUDAKOV | 1 | 1 |  | D |  | H | EUGENE C | 10-042 |  | 11-006 |  |  | 12-054F |  |  |  |  |  |  |  |  | 09-014 |  |  |  |  |  |  |  |  |  |  | 11-026 |  |  |  |  |  |  |  |  |  | 11-001 |  |  |  |  |  |  |  |  |  |  |  |
| 15211080a |  | Test PC Boards (G10) (FWD Chambers) FY11 |  | 101.5d | 2010-07-26 A | 2010-12-17 A | 15211080 | 100% |  |  |  | ELEC TECH [228 h] | 9,609.23 | 9,609.23 | 0 | 9746.371034 | CHUDAKOV | 1 | 1 |  | D |  | H | EUGENE C | 10-042 |  | 11-006 |  |  | 12-054F |  |  |  |  |  |  |  |  | 09-014 |  |  |  |  |  |  |  |  |  |  | 11-026 |  |  |  |  |  |  |  |  |  | 11-001 |  |  |  |  |  |  |  |  |  |  |  |
| 15211005 |  | Proc Chamb Frames (G10) (FWD Chambers) |  | 101d | 2010-08-23 A | 2011-01-24 A | 12321018M, 9-100M FS+151d | 100% |  |  |  | PROCUREMENT<$50K 60 NO ESCALATION FY11; PROCUREMENT>$50K 69 NO ESCALATION FY11 | 152,731.16 |  | 0 | 152731.16 | CHUDAKOV | 1 | 1 |  | D |  | D | EUGENE C | 10-042 |  | 11-006 |  |  | 12-054F |  | 0 | 152731.16 | 15273116 | 100 |  |  |  | 09-014 |  |  |  |  |  |  |  |  |  |  | 11-026 |  |  |  |  |  |  |  |  | APP |  | 08-035 |  |  |  |  |  |  |  |  |  |  |
| 15211002b |  | Engineering Support for Assembly FY11 (FWD Chambers) |  | 248d | 2010-10-01 A | 2011-09-30 A | 15211002a | 100% |  |  |  | MECH DES [160 h]; MECH ENG [20 h] | 8,827.8 | 8,827.8 | 0 | 8827.8 | CHUDAKOV | 1 | 1 |  | D | 07-024 | E | EUGENE C |  |  | 11-006 |  |  | 12-054F |  |  |  |  |  |  |  |  |  |  |  |  |  |  |  |  |  |  |  | 11-026 |  |  |  | 100 | 100 |  | 09-027 | 09-027 |  |  |  |  | 8.46774193 | 91.53225806 |  |  |  |  |  |  |  |
| 15211011E |  | FY11 Travel (FWD Chambers) |  | 248d | 2010-10-01 A | 2011-09-30 A | 15211010E | 100% |  |  |  | TRAVEL | 1,373.07 |  | 0 | 1373.07 | CHUDAKOV | 1 | 1 |  | D | 07-024 | E | EUGENE C |  |  | 11-006 |  |  | 12-054F |  |  |  |  |  |  |  |  |  |  |  |  |  |  |  |  |  |  |  | 11-026 |  |  |  | 100 | 100 |  |  |  |  |  |  |  | 8.46774193 | 91.53225806 |  |  |  |  |  |  |  |
| 15211020a |  | Proc Production PC Boards Cathode Kapton Foil (FWD Chambers) |  | 170d | 2010-10-11 A | 2011-06-20 A | 15211020 FS-11d | 100% |  |  |  | PROCUREMENT<$50K 60 NO ESCALATION FY11; PROCUREMENT>$50K 69 NO ESCALATION FY11 | 90,550.89 |  | 0 | 90550.89 | CHUDAKOV | 1 | 1 |  | D |  | D | EUGENE C | 10-042 |  | 11-006 |  |  | 12-054F |  | 0 | 90550.89 | 9055089 | 100 |  |  |  | 09-014 |  |  |  |  |  |  |  |  |  |  | 11-026 |  |  |  |  |  |  |  |  | APP |  |  |  |  |  |  |  |  |  |  |  |  |
| 15211105 |  | Wire Chamb Frames Prep (FWD Chambers) |  | 37d | 2010-11-15 A | 2011-01-17 A | 15211100 FS-30d, 15211002a FS-55d, 15211005, 197111030M FS-20d | 100% | 2010-11-15 | 2011-01-14 |  | MECH TECH [292 h] | 12,576.44 | 12,576.44 | 0 | 12576.44 | CHUDAKOV | 1 | 1 |  | D |  | H | EUGENE C | 10-042 |  | 11-006 |  |  | 12-054F |  |  |  |  |  |  |  |  | 09-014 |  |  |  |  |  |  |  |  |  |  | 11-026 |  |  |  |  |  |  |  |  |  |  |  |  |  |  |  |  |  |  |  |  |  |
| 15211140 |  | G10 PC Board Prep (FWD Chambers) |  | 36.5d | 2010-11-15 A | 2011-01-17 A | 15211080a | 100% | 2010-11-15 | 2011-01-14 |  | MECH TECH [292 h] | 12,576.44 | 12,576.44 | 0 | 12576.44 | CHUDAKOV | 1 | 1 |  | D |  | H | EUGENE C | 10-042 |  | 11-006 |  |  | 12-054F |  |  |  |  |  |  |  |  | 09-014 |  |  |  |  |  |  |  |  |  |  | 11-026 |  |  |  |  |  |  |  |  |  |  |  |  |  |  |  |  |  |  |  |  |  |
| 15211022 |  | Procuremnt of Rigid Flex Assemblies (FWD Chambers) |  | 164d | 2010-11-22 A | 2011-07-25 A | 12321018M, 9-100M FS+60d | 100% |  |  |  | PROCUREMENT<$50K 60 | 29,814.89 |  | 0 | 29814.89308 | CHUDAKOV | 1 | 1 |  | D |  | D | EUGENE C |  |  | 11-006 |  |  | 12-054F |  | 0 | 29814.89308 | 2981489.308 | 100 |  |  |  | 09-014 |  |  |  |  |  |  |  |  |  |  | 11-026 |  |  |  |  |  |  |  |  | APP |  | 08-035 |  |  |  |  |  |  |  |  |  |  |
| 15211035 |  | Proc Chamb Preamps (ASIC Dsgn) (FWD Chambers) Labor FY10 |  | 15d | 2010-12-01 A | 2010-12-23 A | 9-100M FS+180d | 100% | 2010-12-01 | 2010-12-21 |  | PD UNIV STUDNT [418.46 h] | 4,326.88 | 4,326.88 | 0 | 4192.9692 | CHUDAKOV | 1 | 1 |  | D |  | H | EUGENE C |  |  | 11-006 |  |  | 12-054F |  |  |  |  |  |  |  |  | 09-014 |  |  |  |  |  |  |  |  |  |  | 11-026 |  |  |  |  |  |  |  |  | APP | 11-001 | 08-035 |  |  |  | 10-024 |  |  |  |  |  |  |
| 15211035a |  | Proc Chamb Preamps (ASIC Dsgn) (FWD Chambers) Labor FY11 |  | 19d | 2011-01-01 A | 2011-01-31 A | 15211035 | 100% | 2011-01-04 | 2011-01-31 |  | PD UNIV STUDNT [381.54 h] | 3,945.12 | 3,945.12 | 0 | 3945.1236 | CHUDAKOV | 1 | 1 |  | D |  | H | EUGENE C |  |  | 11-006 |  |  | 12-054F |  |  |  |  |  |  |  |  | 09-014 |  |  |  |  |  |  |  |  |  |  | 11-026 |  |  |  |  |  |  |  |  | APP | 11-001 | 08-035 |  |  |  | 10-024 |  |  |  |  |  |  |
| 15211155 |  | Mount on-Chamb Electrnc's (FWD Chambers) |  | 14d | 2011-01-04 A | 2011-01-24 A | 9-110M FS+33d | 100% |  |  |  | ELEC TECH [209.42 h] | 8,956.89 | 8,956.89 | 0 | 8956.8934 | CHUDAKOV | 1 | 1 |  | D |  | H | EUGENE C | 10-042 |  | 11-006 |  |  | 12-054F |  |  |  |  |  |  |  |  |  |  |  |  |  |  |  |  |  |  |  | 11-026 |  |  |  |  |  |  |  |  |  |  |  |  |  |  |  | 09-012 |  |  |  |  |  |
| 15211145 |  | Procurement of Consumables for Fab (2011) (FWD Chambers) |  | 183.5d | 2011-01-05 A | 2011-09-26 A | 9-110M FS+59d, 15211140 FS-10d | 100% |  |  |  | PROCUREMENT<$50K 60 | 82,200 |  | 0 | 82200 | CHUDAKOV | 1 | 1 |  | D |  | D | EUGENE C | 10-042 |  | 11-006 |  |  | 12-054F |  | 0 | 82200 | 8220000 | 100 |  |  |  |  |  |  |  |  |  |  |  |  |  |  | 11-026 |  |  |  |  |  |  |  |  | APP |  | 08-035 |  |  |  | 10-024 |  | 08-052 |  |  |  |  |
| 15211085 |  | Test PC Boards (Flex) (FWD Chambers) |  | 116d | 2011-01-17 A | 2011-06-30 A | 15211020, 15211020a FS-170d | 100% | 2011-01-18 | 2011-06-30 |  | ELEC TECH [588 h] | 25,148.76 | 25,148.76 | 0 | 25148.76 | CHUDAKOV | 1 | 1 |  | D |  | H | EUGENE C | 10-042 |  | 11-006 |  |  | 12-054F |  |  |  |  |  |  |  |  | 09-014 |  |  |  |  |  |  |  |  |  |  | 11-026 |  |  |  |  |  |  |  |  |  |  |  |  |  |  |  |  |  |  |  |  |  |
| 15211070 |  | Proc Gas Connections (FWD Chambers) |  | 14d | 2011-02-01 A | 2011-02-21 A | 9-110M FS+60d | 100% | 2011-02-01 | 2011-02-18 |  | PROCUREMENT<$50K 60; PROCUREMENT>$50K 69 | 56,691.82 |  | 0 | 56691.82 | CHUDAKOV | 1 | 1 |  | D |  | D | EUGENE C |  |  | 11-006 |  |  | 12-054F |  | 0 | 56691.82 | 5669182 | 100 |  |  |  |  |  |  |  |  |  |  |  |  |  |  | 11-026 |  |  |  |  |  |  |  |  | APP |  |  |  |  |  |  |  |  |  |  |  |  |
| 15211163 |  | Manufacture All Cables & QA (FWD Chambers) |  | 117d | 2011-02-08 A | 2011-07-25 A | 15211050 FS-100d | 100% |  |  |  | MECH TECH [880 h]; ELEC TECH [880 h] | 75,539.2 | 75,539.2 | 0 | 75539.2 | CHUDAKOV | 1 | 1 |  | D |  | D | EUGENE C | 10-042 |  | 11-006 |  |  | 12-054F |  |  |  |  |  |  |  |  |  |  |  |  |  |  |  |  |  |  |  | 11-026 |  |  |  |  |  |  |  |  |  |  |  |  |  |  |  |  |  |  |  |  |  |
| 15211102 |  | Set-up Clean Room for Production |  | 29d | 2011-02-14 A | 2011-03-25 A | 9-110M FS+59d | 100% |  |  |  | MECH ENG [240 h]; MECH TECH [480 h] | 36,981.6 | 36,981.6 | 0 | 36981.6 | CHUDAKOV | 1 | 1 |  | D |  | H | EUGENE C | 10-042 |  | 11-006 |  |  | 12-054F |  |  |  |  |  |  |  |  | 09-014 |  |  |  |  |  |  |  |  |  |  | 11-026 |  |  |  |  |  |  |  |  |  |  |  |  |  |  |  |  |  |  |  |  |  |
| 15211035b |  | ASIC Fabrication (FDC&CDC) |  | 118d | 2011-03-01 A | 2011-08-15 A | 9-100M FS+180d, 1546005 | 100% |  |  |  | PROCUREMENT<$50K 60; PROCUREMENT>$50K 69 | 160,000 |  | 0 | 160000 | CHUDAKOV | 1 | 1 |  | D |  | D | EUGENE C |  |  | 11-006 |  |  | 12-054F |  | 0 | 160000 | 16000000 | 100 |  |  |  | 09-014 |  |  |  |  |  |  |  |  |  |  | 11-026 |  |  |  |  |  |  |  |  | APP | 11-001 | 08-035 |  |  |  | 10-024 |  |  |  |  |  |  |
| 15211120 |  | Cathode Frame Inspection (FWD Chambers) |  | 18d | 2011-03-01 A | 2011-03-25 A | 15211002b FS-233d, 15211100, 15211085 FS-166d | 100% |  |  |  | MECH TECH [176 h] | 7,580.32 | 7,580.32 | 0 | 7580.32 | CHUDAKOV | 1 | 1 |  | D |  | H | EUGENE C | 10-042 |  | 11-006 |  |  | 12-054F |  |  |  |  |  |  |  |  | 09-014 |  |  |  |  |  |  |  |  |  |  | 11-026 |  |  |  |  |  |  |  |  |  |  |  |  |  |  |  |  |  |  |  |  |  |
| 15211125 |  | Cell #1Assy. (FWD Chambers) |  | 55d | 2011-04-02 A | 2011-06-20 A | 15211100, 15211105, 15211002b FS-128d, 15211102 | 100% | 2011-04-04 | 2011-06-20 |  | MECH DES [160 h]; MECH ENG [240 h]; ELEC TECH [160 h]; SCIENTIST [160 h]; MECH TECH [720 h] | 72,579.2 | 72,579.2 | 0 | 72579.2 | CHUDAKOV | 1 | 1 |  | D |  | S | EUGENE C | 10-042 |  | 11-006 |  |  | 12-054F |  |  |  |  |  |  |  |  | 09-014 |  |  | ST |  |  |  |  |  |  |  | 11-026 |  |  |  |  |  |  |  |  |  |  |  |  |  |  |  |  |  |  |  |  |  |
| 15211094 |  | Acceptance Preamp Daughter Board (FWD Chambers) |  | 11d | 2011-04-03 A | 2011-04-18 A | 9-120M, 15211035a, 15211035b | 100% | 2011-04-04 | 2011-04-18 |  |  |  |  |  | 0 | CHUDAKOV | 1 | 1 |  | D |  | Z | EUGENE C |  |  | 11-006 |  |  | 12-054F |  |  |  |  |  |  |  |  | 09-014 |  |  |  |  |  |  |  |  |  |  | 11-026 |  |  |  |  |  |  |  |  |  |  |  |  |  |  |  |  |  |  |  |  |  |
| 15211060 |  | Proc Cooling Sys (FWD Chambers) Part A |  | 490d | 2011-04-11 A | 2012-12-17 A | 9-110M | 100% | 2011-04-11 | 2013-04-01 |  | PROCUREMENT<$50K 60 | 14,472.41 |  | 0 | 14472.41 | CHUDAKOV | 1 | 1 |  | D |  | D | EUGENE C |  |  | 11-006 |  |  | 12-054F |  | 0 | 14472.41 | 1447241 | 100 |  |  |  |  |  |  |  |  |  |  |  |  |  |  | 11-026 |  |  |  |  |  |  |  |  | APP |  |  |  |  |  |  |  |  | 12-055 |  |  |  |
| 15211126 |  | Package #1 Fabrication (FWD Chambers) |  | 122.5d | 2011-04-25 A | 2011-10-17 A | 15211002b FS-255d, 15211090a FS-30d, 15211080a FS-30d, 15211125 FS-20d, 15211120 FS-130d, 15211022 FS-60d, 15211030a FS-30d | 100% |  |  |  | SCIENTIST [160 h]; ELEC TECH [160 h]; MECH DES [160 h]; MECH ENG [320 h]; MECH TECH [3400 h] | 193,995.69 | 193,995.69 | 0 | 193442.8 | CHUDAKOV | 1 | 1 |  | D |  | S | EUGENE C | 10-042 |  | 11-006 |  |  | 12-054F |  |  |  |  |  |  |  |  | 09-014 |  |  | ST |  |  |  |  |  |  |  | 11-026 |  |  |  |  |  |  |  |  |  |  |  |  |  |  |  |  |  |  |  |  |  |
| 15211002c |  | Additional Engineering Support for Assembly FY12 (FWD Chambers) |  | 86d | 2011-06-01 A | 2011-09-30 A | 15211002b FS-84d | 100% |  |  |  | MECH DES [160 h]; MECH ENG [20 h] | 8,827.8 | 8,827.8 | 0 | 8827.8 | CHUDAKOV | 1 | 1 |  | D | 07-024 | E | EUGENE C |  |  | 11-006 |  |  | 12-054F |  |  |  |  |  |  |  |  |  |  |  |  |  |  |  |  |  |  |  | 11-026 |  |  |  | 100 | 100 |  | 09-027 | 09-027 |  |  |  |  | 25 | 75 |  |  |  |  |  |  |  |
| 15211163a |  | Support for procurement of parts for gas system (FWD Chambers) |  | 65d | 2011-06-01 A | 2011-08-31 A | 9-110M FS+162d | 100% |  |  |  | SCIENTIST [160 h] | 10,948.8 | 10,948.8 | 0 | 10948.8 | CHUDAKOV | 1 | 1 |  | D |  | H | EUGENE C |  |  | 11-006 |  |  | 12-054F |  |  |  |  |  |  |  |  |  |  |  |  |  |  |  |  |  |  |  | 11-026 |  |  |  |  |  |  |  |  |  |  |  |  |  |  |  |  |  |  |  |  |  |
| 15211130 |  | Package #2 Fabrication (FWD Chambers) FY11 |  | 97.49d | 2011-08-15 A | 2012-01-10 A | 15211126 FS-20d | 100% |  |  |  | MECH DES [6.64 h]; MECH ENG [23.23 h]; SCIENTIST [13.27 h]; ELEC TECH [13.27 h]; MECH TECH [282.03 h] | 15,832.59 | 15,841.55 | 0 | 15511.0898 | CHUDAKOV | 1 | 1 |  | D |  | S | EUGENE C | 10-042 |  | 11-006 |  |  | 12-054F |  |  |  |  |  |  |  |  | 09-014 |  |  | ST |  |  |  |  |  |  |  | 11-026 |  |  |  |  |  |  |  |  |  |  |  |  |  |  |  |  |  |  | 12-001 |  |  |
| 15211130a |  | Package #2 Fabrication (FWD Chambers) FY12 |  | 101d | 2011-08-15 A | 2012-01-16 A | 15211130 FS-100d | 100% | 2011-08-15 | 2012-01-13 |  | MECH TECH [3117.97 h]; MECH DES [73.36 h]; MECH ENG [256.77 h]; SCIENTIST [146.73 h]; ELEC TECH [146.73 h] | 175,099.66 | 175,099.66 | 0 | 176936.8506 | CHUDAKOV | 1 | 1 |  | D |  | S | EUGENE C | 10-042 |  | 11-006 |  |  | 12-054F |  |  |  |  |  |  |  |  | 09-014 |  |  | ST |  |  |  |  |  |  |  | 11-026 |  |  |  |  |  |  |  |  |  |  |  |  |  |  |  |  |  |  | 12-001 |  |  |
| 15211012E |  | FY12 Travel (FWD Chambers) |  | 247d | 2011-10-03 A | 2012-09-28 A | 15211011E | 100% |  |  |  | TRAVEL | 1,418.05 |  | 0 | 1418.05 | CHUDAKOV | 1 | 1 |  | D | 07-024 | E | EUGENE C |  |  | 11-006 |  |  | 12-054F |  |  |  |  |  |  |  |  |  |  |  |  |  |  |  |  |  |  |  | 11-026 |  |  |  | 100 | 100 |  |  |  |  |  |  |  | 7.69230769 | 92.3076923 |  |  |  |  |  |  |  |
| 15211190 |  | Procurement of Consumables for Fab (2012) (FWD Chambers) |  | 247d | 2011-10-03 A | 2012-09-28 A | 9-120M | 100% |  |  |  | PROCUREMENT<$50K 60 | 11,866.85 |  | 0 | 11866.85 | CHUDAKOV | 1 | 1 |  | D |  | E | EUGENE C | 10-042 |  | 11-006 |  |  | 12-054F |  | 0 | 11866.85 | 1186685 | 100 |  |  |  | 09-014 |  |  |  |  |  |  |  |  |  |  | 11-026 |  |  |  | 100 | 100 |  |  |  |  |  |  |  | 7.69230769 | 92.3076923 |  |  |  |  |  |  |  |
| 15211075 |  | Proc Supprt Frame (FWD Chambers) Part A |  | 235d | 2011-12-05 A | 2012-11-12 A | 15211001c FS-180d, 9-120M, 15211001d FS-182d, 15211001b FS-60d | 100% |  |  |  | PROCUREMENT<$50K 60 | 37,476 |  | 0 | 37476 | CHUDAKOV | 1 | 1 |  | D |  | D | EUGENE C | 10-042 |  | 11-006 |  |  | 12-054F |  | 0 | 37476 | 3747600 | 100 |  |  |  | 09-014 |  |  |  |  |  |  |  |  |  |  | 11-026 |  |  |  |  |  |  |  |  | APP |  |  | 09-046 |  |  |  |  |  | 12-055 |  | 15211075 |  |
| 15211150 |  | 1st Package Final Assy. and Testing (FWD Chambers) |  | 191d | 2012-01-16 A | 2012-10-15 A | 15211094 FS-15d, 1546090 FS-80d, 15211145, 15211164 FS-110d | 100% | 2012-01-17 | 2012-10-15 |  | SCIENTIST [160 h]; ELEC TECH [40 h]; MECH TECH [320 h]; MECH ENG [80 h] | 32,953.67 | 32,953.67 | 0 | 32893.2 | CHUDAKOV | 1 | 1 |  | D |  | S | EUGENE C |  |  | 11-006 |  |  | 12-054F |  |  |  |  |  |  |  |  | 09-014 |  |  | ST |  |  |  |  |  |  |  | 11-026 |  |  |  |  |  |  |  |  |  |  |  |  |  |  |  |  |  |  |  |  |  |
| 15211135 |  | Package #3 Fabrication (FWD Chambers) |  | 84d | 2012-01-16 A | 2012-05-14 A | 15211130a FS-9d | 100% | 2012-01-17 | 2012-05-14 |  | MECH DES [80 h]; MECH ENG [280 h]; MECH TECH [3400 h]; SCIENTIST [160 h]; ELEC TECH [160 h] | 192,941.6 | 192,941.6 | 0 | 192941.6 | CHUDAKOV | 1 | 1 |  | D |  | S | EUGENE C | 10-042 |  | 11-006 |  |  | 12-054F |  |  |  |  |  |  |  |  | 09-014 |  |  | ST |  |  |  |  |  |  |  | 11-026 |  |  |  |  |  |  |  |  |  |  |  |  |  |  |  |  |  |  |  |  |  |
| 15211095 |  | Test Electrnc's (FWD Chambers) |  | 179d | 2012-03-02 A | 2012-11-12 A | 9-120M FS+115d | 100% |  |  |  | ELEC TECH [880 h] | 39,049.29 | 39,049.29 | 0 | 38834.4 | CHUDAKOV | 1 | 1 |  | D |  | U | EUGENE C |  |  | 11-006 |  |  | 12-054F |  |  |  |  |  |  |  |  | 09-014 |  |  |  |  |  |  |  |  |  |  | 11-026 |  |  |  |  |  |  |  |  |  |  |  |  |  |  |  |  |  |  |  |  |  |
| 15211249 |  | Construct/Install/Test HV Sys (FWD Chambers) |  | 109d | 2012-03-12 A | 2012-08-13 A | 9-120M FS+105d, 15211163 | 100% |  |  |  | ELEC TECH [296 h]; MECH TECH [296 h] | 26,216.72 | 26,216.72 | 0 | 26216.72 | CHUDAKOV | 1 | 1 |  | D |  | H | EUGENE C | 10-042 |  | 11-006 |  |  | 12-054F |  |  |  |  |  |  |  |  |  |  |  |  |  |  |  |  |  |  |  | 11-026 |  |  |  |  |  |  |  |  |  |  |  |  |  |  |  |  |  |  |  |  |  |
| 15211250 |  | Construct/Install/Test LV Sys ((FWD Chambers) |  | 205d | 2012-03-12 A | 2013-01-14 A | 9-120M FS+105d | 100% | 2012-03-12 | 2013-01-07 |  | ELEC TECH [296 h]; MECH TECH [296 h] | 26,474.15 | 26,487.97 | 0 | 26216.72 | CHUDAKOV | 1 | 1 |  | D |  | H | EUGENE C |  |  | 11-006 |  |  | 12-054F | XX |  |  |  |  |  |  |  |  |  |  |  |  |  |  |  |  |  |  | 11-026 |  |  |  |  |  |  |  |  |  |  |  |  |  |  |  |  |  |  |  |  |  |
| 15211141 |  | Package #4 Fabrication (FWD Chambers) FY12 |  | 214.5d | 2012-04-09 A | 2013-02-11 A | 15211135 FS-70d | 100% | 2012-04-09 | 2013-02-20 |  | MECH TECH [3281.74 h]; MECH DES [77.22 h]; MECH ENG [270.26 h]; ELEC TECH [154.43 h]; SCIENTIST [154.43 h] | 188,795.81 | 188,703.72 | 0 | 186230.1424 | CHUDAKOV | 1 | 1 |  | D |  | S | EUGENE C | 10-042 |  | 11-006 |  |  | 12-054F | XX |  |  |  |  |  |  |  | 09-014 |  |  | ST |  |  |  |  |  |  |  | 11-026 |  |  |  |  |  |  |  |  |  |  |  |  |  |  |  |  |  |  |  |  | 12-053 |
| 15211141a |  | Package #4 Fabrication (FWD Chambers) FY13 |  | 215d | 2012-04-09 A | 2013-02-11 A | 15211141 FS-100d | 100% | 2012-04-09 | 2013-02-20 |  | MECH ENG [9.74 h]; ELEC TECH [5.57 h]; SCIENTIST [5.57 h]; MECH TECH [118.26 h]; MECH DES [2.78 h] | 6,804.2 | 6,800.7 | 0 | 6925.8718 | CHUDAKOV | 1 | 1 |  | D |  | S | EUGENE C | 10-042 |  | 11-006 |  |  | 12-054F | XX |  |  |  |  |  |  |  | 09-014 |  |  | ST |  |  |  |  |  |  |  | 11-026 |  |  |  |  |  |  |  |  |  |  |  |  |  |  |  |  |  |  |  |  | 12-053 |
| 15211164 |  | Construct/ Test Gas System (FWD Chambers) |  | 108d | 2012-04-16 A | 2012-09-17 A | 9-120M FS+141d, 15211070, 15211002b FS-245d, 15211163a | 100% |  |  |  | MECH DES [280 h]; MECH TECH [320 h]; MECH ENG [200 h] | 41,732.4 | 41,732.4 | 0 | 41732.4 | CHUDAKOV | 1 | 1 |  | D |  | H | EUGENE C |  |  | 11-006 |  |  | 12-054F |  |  |  |  |  |  |  |  |  |  |  |  |  |  |  |  |  |  |  | 11-026 |  |  |  |  |  |  |  |  |  |  |  |  |  |  |  |  |  |  |  |  |  |
| 15211155a |  | 2nd Package Final Assy. and Testing (FWD Chambers) FY12 |  | 50d | 2012-10-01 A | 2013-01-14 A | 15211155, 15211150 FS-1d | 100% | 2012-10-01 | 2012-12-11 |  | ELEC TECH [25.37 h]; MECH ENG [50.73 h]; MECH TECH [202.93 h]; SCIENTIST [101.46 h] | 21,524.92 | 21,524.92 | 0 | 20859.0655 | CHUDAKOV | 1 | 1 |  | D |  | S | EUGENE C | 10-042 |  | 11-006 |  |  | 12-054F | XX |  |  |  |  |  |  |  |  |  |  | ST |  |  |  |  |  |  |  | 11-026 |  |  |  |  |  |  |  |  |  |  |  |  |  |  |  | 09-012 |  |  |  |  | 12-053 |
| 15211155aa |  | 2nd Package Final Assy. and Testing (FWD Chambers) FY13 |  | 50d | 2012-10-01 A | 2013-01-14 A | 15211155a FS-40d | 100% | 2012-10-01 | 2012-12-11 |  | MECH ENG [29.27 h]; MECH TECH [117.07 h]; SCIENTIST [58.54 h]; ELEC TECH [14.63 h] | 12,418.28 | 12,418.28 | 0 | 12418.282 | CHUDAKOV | 1 | 1 |  | D |  | S | EUGENE C | 10-042 |  | 11-006 |  |  | 12-054F | XX |  |  |  |  |  |  |  |  |  |  | ST |  |  |  |  |  |  |  | 11-026 |  |  |  |  |  |  |  |  |  |  |  |  |  |  |  | 09-012 |  |  |  |  | 12-053 |
| 15211191 |  | Procurement of Consumables for Fab (2013) (FWD Chambers) |  | 100d | 2012-10-01 A | 2013-08-30 A | 15211190, 9-130M | 100% | 2012-10-01 | 2013-03-01 |  | PROCUREMENT<$50K 60 | 11,925.96 |  | 3577.788 | 11925.96 | CHUDAKOV | 1 | 1 |  | D |  | D | EUGENE C | 10-042 |  | 11-006 |  |  | 12-054F | XX | 0 | 11925.96 | 1192596 | 100 |  |  |  | 09-014 |  |  |  |  |  |  |  |  |  |  | 11-026 |  |  |  | 100 | 100 |  |  |  |  |  |  |  | 41 | 59 |  |  |  |  |  |  |  |
| 15211195 |  | Cell #25 Assy. (FWD Chambers) |  | 53d | 2012-10-15 A | 2013-03-11 A | 9-130M, 15211135 | 100% | 2012-10-15 | 2013-01-07 |  | MECH TECH [480 h]; MECH ENG [40 h] | 24,907.2 | 24,907.2 | 0 | 24136 | CHUDAKOV | 1 | 1 |  | D |  | S | EUGENE C | 10-042 |  | 11-006 |  |  | 12-054F | XX |  |  |  |  |  |  |  | 09-014 |  |  | ST |  |  |  |  |  |  |  | 11-026 |  |  |  |  |  |  |  |  |  |  |  |  |  |  |  |  |  |  |  |  |  |

Notes:
- 251173f: Steps: install manifold sections (done); install turbo pump and pump down (done); leak check system (done)
- 251195: Steps: Repair Solenoid Vac Leaks (done)
- 15211000a: Steps: Lab Equipment1 (done); Rigid Flex1 (done); Machine Tensioning Fixture (done); Assembly Jig For Cathode Ring (done); Assembly Jig for Package Assy. (done)
- 15211000b: Steps: Wire Planes Preparations (done); Cathode Planes Preparations (done); Package Assembly (done); Service Infrastructure (done)
- 15211002a: Steps: Fabrication Set-up (done); Chamber Frames Prep (done); Finish Protoyping (done); First Article (done); Finish FY10 Scope (done)
- 15211100: Steps: Prepare The 1st Clean Tent (done); Initial Set of Tooling (done); Prepare The 2nd Clean Tent (done); Prepare the Room and Space/ Granite table purchased (done); Build Gas Tight Storage Area (done); Equipment for Soldering and HV Test (done); Set up wire tensioning equipment (done)
- 15211125: Steps: Bond Cathode Foil to frames (done); Bond Ground plane (done); Bond PCB's to wire plane (done); Install Rigid flex (done); String wires on anode plane (done); Mount chamber electronics (done); Assemble Gas spacer (done); assemble single cell (done); Test cell (done)
- 15211126: Steps: Cell 2 Fabrication (done); Cell 2 Elecrical Testing (done); Cell 3 Fabrication (done); Cell 3 Electrical Testing (done); Cell 4 Fabrication (done); Cell 4 Electrical Testing (done); Cell 5 Fabrication (done); Cell 5 Electrical Testing (done); Cell 6 Fabrication (done); Cell 6 Electrical Testing (done); Assemble package (done); Preliminary test of package (done)
- 15211130: Steps: Cell 1 Fabrication (done); Cell 1 Elecrical Testing (done); Cell 2 Fabrication (done); Cell 2 Elecrical Testing (done); Cell 3 Fabrication (done); Cell 3 Electrical Testing (done); Cell 4 Fabrication (done); Cell 4 Electrical Testing (done); Cell 5 Fabrication (done); Cell 5 Electrical Testing (done); Cell 6 Fabrication (done); Cell 6 Electrical Testing (done); Assemble package (done); Preliminary test of package (done)
- 15211130a: Steps: Cell 1 Fabrication (done); Cell 1 Elecrical Testing (done); Cell 2 Fabrication (done); Cell 2 Elecrical Testing (done); Cell 3 Fabrication (done); Cell 3 Electrical Testing (done); Cell 4 Fabrication (done); Cell 4 Electrical Testing (done); Cell 5 Fabrication (done); Cell 5 Electrical Testing (done); Cell 6 Fabrication (done); Cell 6 Electrical Testing (done); Assemble package (done); Preliminary test of package (done)
- 15211150: Steps: Install Preamp cards (done); Install Cooling (done); Condition with gas (done); Electrical tests (done); Resolution checks (done)
- 15211135: Steps: Cell 1 Fabrication (done); Cell 1 Elecrical Testing (done); Cell 2 Fabrication (done); Cell 2 Elecrical Testing (done); Cell 3 Fabrication (done); Cell 3 Electrical Testing (done); Cell 4 Fabrication (done); Cell 4 Electrical Testing (done); Cell 5 Fabrication (done); Cell 5 Electrical Testing (done); Cell 6 Fabrication (done); Cell 6 Electrical Testing (done); Assemble package (done); Preliminary test of package (done)
- 15211141: Steps: Cell 1 Fabrication (done); Cell 1 Elecrical Testing (done); Cell 2 Fabrication (done); Cell 2 Elecrical Testing (done); Cell 3 Fabrication (done); Cell 3 Electrical Testing (done); Cell 4 Fabrication (done); Cell 4 Electrical Testing (done); Cell 5 Fabrication (done); Cell 5 Electrical Testing (done); Cell 6 Fabrication (done); Cell 6 Electrical Testing (done); Assemble package (done); Preliminary test of package (done)
- 15211141a: Steps: Cell 1 Fabrication (done); Cell 1 Elecrical Testing (done); Cell 2 Fabrication (done); Cell 2 Elecrical Testing (done); Cell 3 Fabrication (done); Cell 3 Electrical Testing (done); Cell 4 Fabrication (done); Cell 4 Electrical Testing (done); Cell 5 Fabrication (done); Cell 5 Electrical Testing (done); Cell 6 Fabrication (done); Cell 6 Electrical Testing (done); Assemble package (done); Preliminary test of package (done)
- 15211155a: Steps: Install Preamp cards (done); Install Cooling (done); Condition with gas (done); Electrical tests (done); Resolution checks (done)
- 15211155aa: Steps: Install Preamp cards (done); Install Cooling (done); Condition with gas (done); Electrical tests (done); Resolution checks (done)
- 15211195: Steps: Bond Cathode Foil to frames (done); Bond Ground plane (done); Bond PCB's to wire plane (done); Install Rigid flex (done); String wires on anode plane (done); Mount chamber electronics (done); Assemble Gas spacer (done); assemble single cell (done); Test cell (done)

| ID | Activity | Duration | Start | Finish | Predecessors | Complete | Remaining | Planned start | Planned finish | Total float | Free float | Calendar | Resources | Cost | Actual cost | Calculated Remaining Total Cost | MONTHLY EV COST | RESP - Responsibility | STRT%COMP for CM EVM | FNSH%COMP for CM EVM | HALL D Related Milestones | EVMS Reporting Codes | CAM RESPONSIBLE | Activities with Steps | CR 09-014 | CR 10-042 | CR 11-006 | CR 11-026 | CR 12-054 | MARCH!!! | CR 09-012 | CR 12-053 | Remaining Material Cost Based on % Compl | Claimed Material Cost Based on % Complet | Initial Claimed Material Calc | Claimed Material Divider | Advance Purchase Plan > 500K | CR 12-055 | Specification | CR 09-046 | ReBaseline Actuals Adjustment | Original Activity ID Rebaseline | CR 13-007 | BOE Labor | CR 13-015 | Post Rebaseline | CR 14-001 | PRIOR MONTH EV COST | BOE Expenses | LOE % Pre Calc | LOE % | LOE Divider | LOE Multiplier | Obligated Prior to Rebaseline |
| --- | --- | --- | --- | --- | --- | --- | --- | --- | --- | --- | --- | --- | --- | --- | --- | --- | --- | --- | --- | --- | --- | --- | --- | --- | --- | --- | --- | --- | --- | --- | --- | --- | --- | --- | --- | --- | --- | --- | --- | --- | --- | --- | --- | --- | --- | --- | --- | --- | --- | --- | --- | --- | --- | --- |
| 15211200 | Cell #26 Assy. (FWD Chambers) | 53d | 2012-10-15 A | 2013-03-11 A | 15211195 FS-30d | 100% |  | 2012-10-15 | 2013-01-07 |  |  |  | MECH TECH [480 h]; MECH ENG [40 h] | 24,907.2 | 24,907.2 | 0 | 24136 | CHUDAKOV | 1 | 1 | D | S | EUGENE C | ST | 09-014 | 10-042 | 11-006 | 11-026 | 12-054F | XX |  |  |  |  |  |  |  |  |  |  |  |  |  |  |  |  |  |  |  |  |  |  |  |  |
| 15211160 | 3rd Package Final Assy. and Testing (FWD Chambers) | 34d | 2012-11-12 A | 2013-02-11 A | 15211155aa FS-40d, 15211155 | 100% |  | 2012-11-12 | 2013-01-08 |  |  |  | MECH ENG [80 h]; MECH TECH [320 h]; SCIENTIST [40 h]; ELEC TECH [40 h] | 25,200 | 25,200 | 0 | 25200 | CHUDAKOV | 1 | 1 | D | S | EUGENE C | ST |  | 10-042 | 11-006 | 11-026 | 12-054F |  | 09-012 |  |  |  |  |  |  |  |  |  |  |  |  |  |  |  |  |  |  |  |  |  |  |  |
| 15211205 | Cell #27 Assy. (FWD Chambers) | 11d | 2012-12-03 A | 2013-03-11 A | 15211200 FS-40d, 9-130M | 100% |  | 2013-01-31 | 2013-02-14 |  |  |  | MECH ENG [40 h]; MECH TECH [480 h] | 24,907.2 | 24,907.2 | 0 | 24907.2 | CHUDAKOV | 1 | 1 | D | S | EUGENE C | ST | 09-014 | 10-042 | 11-006 | 11-026 | 12-054 | XX |  | 12-053 |  |  |  |  |  |  |  |  |  |  |  |  |  |  |  |  |  |  |  |  |  |  |
| 15211060a | Proc Cooling Sys (FWD Chambers) Part B | 98d | 2012-12-10 A | 2013-05-13 A | 9-110M | 100% |  | 2013-01-02 | 2013-05-21 |  |  |  | PROCUREMENT<$50K 60 | 10,472 |  | 0 | 10472 | CHUDAKOV | 1 | 1 | D | D | EUGENE C |  |  |  | 11-006 | 11-026 | 12-054F |  |  |  | 0 | 10472 | 1047200 | 100 | APP | 12-055 |  |  |  |  |  |  |  |  |  |  |  |  |  |  |  |  |
| 15211075a | Proc Supprt Frame (FWD Chambers) Part B | 20d | 2013-01-02 A | 2013-02-11 A | 15211001c FS-180d, 15211001d FS-182d, 15211001b FS-60d, 9-120M | 100% |  | 2013-02-01 | 2013-03-01 |  |  |  | PROCUREMENT<$50K 60 | 3,800 |  | 0 | 3800 | CHUDAKOV | 1 | 1 | D | D | EUGENE C |  | 09-014 | 10-042 | 11-006 | 11-026 | 12-054F | XX |  |  | 0 | 3800 | 380000 | 100 | APP | 12-055 | 15211075 | 09-046 |  |  |  |  |  |  |  |  |  |  |  |  |  |  |
| 15211165 | 4th Package Final Assy. and Testing (FWD Chambers) | 22d | 2013-01-07 A | 2013-03-11 A | 15211141a FS-20d, 15211249, 15211160 FS-65d, 15211250 FS-40d, 15211095 | 100% |  | 2013-05-30 | 2013-06-28 |  |  |  | MECH TECH [320 h]; MECH ENG [40 h]; SCIENTIST [120 h] | 26,312.8 | 26,312.8 | 0 | 26312.8 | CHUDAKOV | 1 | 1 | D | S | EUGENE C | ST |  |  | 11-006 | 11-026 | 12-054 |  |  |  |  |  |  |  |  |  |  |  |  |  |  |  |  |  |  |  |  |  |  |  |  |  |
| 15211210 | Cell #28 Assy. (FWD Chambers) | 24.5d | 2013-01-28 A | 2013-04-15 A | 15211205 FS-35d | 100% |  | 2013-03-01 | 2013-04-04 |  |  |  | MECH TECH [480 h]; MECH ENG [40 h] | 24,907.2 | 24,907.2 | 0 | 24907.2 | CHUDAKOV | 1 | 1 | D | S | EUGENE C | ST | 09-014 | 10-042 | 11-006 | 11-026 | 12-054 |  |  |  |  |  |  |  |  |  |  |  |  |  |  |  |  |  |  |  |  |  |  |  |  |  |
| 15211185 | Fiducialize complete package (FWD Chambers) | 22d | 2013-02-11 A | 2013-07-15 A | 15211175 FS-150d | 100% |  | 2013-05-14 | 2013-06-13 |  |  |  | MECH ENG [40 h]; SCIENTIST [200 h]; MECH TECH [120 h] | 22,969.6 | 22,969.6 | 22969.6 | 22969.6 | CHUDAKOV | 1 | 1 | D | H | EUGENE C |  | 09-014 | 10-042 | 11-006 | 11-026 | 12-054 |  |  |  |  |  |  |  |  |  |  |  |  |  |  |  |  |  |  |  |  |  |  |  |  |  |
| 15211230 | Alignment Procedures (FWD Chambers) | 76d | 2013-02-11 A | 2013-07-15 A | 15211175 FS-125d, 15211002c FS-245d | 100% |  | 2013-05-01 | 2013-08-16 |  |  |  | ELEC TECH [80 h]; MECH TECH [160 h] | 10,980.8 | 10,980.8 | 5490.4 | 10980.8 | CHUDAKOV | 1 | 1 | D | H | EUGENE C |  | 09-014 | 10-042 | 11-006 | 11-026 | 12-054 |  |  |  |  |  |  |  |  |  |  |  |  |  |  |  |  |  |  |  |  |  |  |  |  |  |
| 15211175 | Complete Package Assy (FWD Chambers) | 118d | 2013-06-01 A | 2013-08-30 A | 15211060a FS-80d, 15211135, 15211075a, 15211060 FS-80d, 15211150, 15211160 FS-30d, 15211145, 15211075, 15211165 FS-52d | 100% |  | 2013-07-01 | 2013-12-17 |  |  |  | ELEC TECH [40 h]; MECH DES [120 h]; MECH ENG [120 h]; MECH TECH [320 h]; SCIENTIST [80 h] | 37,513.45 | 36,974 | 25881.8 | 36974 | CHUDAKOV | 1 | 1 | D | S | EUGENE C | ST | 09-014 | 10-042 | 11-006 | 11-026 | 12-054 |  |  |  |  |  |  |  |  |  |  |  |  |  |  |  |  |  |  |  |  |  |  |  |  |  |
| 15211220 | Final Testing (FWD Chambers) | 23d | 2013-07-01 A | 2013-07-15 A | 15211175 FS-22d, 15211145 | 100% |  | 2013-10-11 | 2013-11-12 |  |  |  | MECH TECH [160 h]; SCIENTIST [160 h] | 19,600 | 18,995.2 | 18995.2 | 18995.2 | CHUDAKOV | 1 | 1 | D | H | EUGENE C |  |  | 10-042 | 11-006 | 11-026 | 12-054 |  | 09-012 |  |  |  |  |  |  |  |  |  |  |  |  |  |  |  |  |  |  |  |  |  |  |  |
| 15211255 | Re-Baseline Actuals Adjustment | 1d | 2013-08-30 A | 2013-08-30 A |  | 100% |  | 2013-09-03 | 2013-09-03 |  |  |  | PROCUREMENT>$50K 69 NO ESCALATION | 756,128.94 |  |  | 756128.94 |  |  |  |  |  |  |  |  |  |  |  |  |  |  |  | 0 | 756128.94 | 75612894 | 100 |  |  |  |  | ADJ |  |  |  |  |  |  |  |  |  |  |  |  |  |
| 25211172 | Resolution_studies_(FWD_Chambers) FY13 | 30d | 2013-09-03 A | 2013-12-12 | 9-130M FS+228d | 50% | 28d | 2013-10-01 | 2013-11-11 | 33d | 12d | 8/5 M-F w/JLAB Holidays ReBaseline | SCIENTIST [64 h] | 4,811.52 | 2,872.19 |  | 2331.52 | CHUDAKOV | 1 | 1 | D | S | EUGENE C | ST | 09-014 | 10-042 | 11-006 | 11-026 | 12-054 |  |  |  |  |  |  |  |  |  |  |  |  | 25211172 | 13-007 | PE | 13-015 | PR |  |  |  |  |  |  |  |  |
| 25211172a | Resolution_studies_(FWD_Chambers) FY14 | 10d | 2013-09-03 A | 2013-12-12 | 25211172 FS-60d | 50% | 28d | 2013-10-01 | 2013-10-14 | 33d | 12d | 8/5 M-F w/JLAB Holidays ReBaseline | SCIENTIST [32 h] | 2,405.76 | 1,436.1 |  | 1202.88 | CHUDAKOV | 1 | 1 | D | S | EUGENE C | ST | 09-014 | 10-042 | 11-006 | 11-026 | 12-054 |  |  |  |  |  |  |  |  |  |  |  |  | 25211172 | 13-007 | PE | 13-015 | PR | 14-001 |  |  |  |  |  |  |  |
| 25211175 | Complete Package Mechanical Assy (FWD Chambers) FY13 | 30d | 2013-09-03 A | 2013-10-21 A | 9-130M FS+228d | 100% |  | 2013-10-01 | 2013-11-11 |  |  | 8/5 M-F w/JLAB Holidays ReBaseline | MECH ENG [5.33 h]; MECH TECH [16 h]; SCIENTIST [5.33 h] | 1,556.51 | 1,545 |  | 754.2276 | CHUDAKOV | 1 | 1 | D | S | EUGENE C | ST | 09-014 | 10-042 | 11-006 | 11-026 | 12-054 |  |  |  |  |  |  |  |  |  |  |  |  | 25211175 | 13-007 | EJ | 13-015 | PR |  | 754.2276 |  |  |  |  |  |  |
| 25211175a | Complete Package Mechanical Assy (FWD Chambers) FY14 | 10d | 2013-09-03 A | 2013-10-21 A | 25211175 FS-25d | 100% |  | 2013-10-01 | 2013-10-14 |  |  | 8/5 M-F w/JLAB Holidays ReBaseline | MECH ENG [2.67 h]; MECH TECH [8 h]; SCIENTIST [2.67 h] | 777.97 | 770.9 |  | 388.98273 | CHUDAKOV | 1 | 1 | D | S | EUGENE C | ST | 09-014 | 10-042 | 11-006 | 11-026 | 12-054 |  |  |  |  |  |  |  |  |  |  |  |  | 25211175 | 13-007 | EJ | 13-015 | PR | 14-001 | 388.98273 |  |  |  |  |  |  |
| 25211191 | Procurement of Consumables for Fab (2013) (FWD Chambers) | 20d | 2013-09-03 A | 2013-09-23 A | 9-130M FS+228d | 100% |  | 2013-10-01 | 2013-10-28 |  |  | 8/5 M-F w/JLAB Holidays ReBaseline | SUPPLIES & MATERIALS | 1,093.6 |  |  | 0 | CHUDAKOV | 1 | 1 | D | U | EUGENE C |  | 09-014 | 10-042 | 11-006 | 11-026 | 12-054F |  |  |  |  |  |  |  |  |  |  |  |  | 25211191 | 13-007F |  | 13-015 | PR |  | 1093.6 | PE |  |  |  |  |  |
| 25211208 | Assemble and Electrical Test of Package R (FDC) | 20d | 2013-09-03 A | 2013-09-23 A | 9-130M FS+228d | 100% |  | 2013-10-01 | 2013-10-28 |  |  | 8/5 M-F w/JLAB Holidays ReBaseline | MECH TECH [32 h]; SCIENTIST [16 h] | 2,717.12 | 2,633.28 |  | 0 | CHUDAKOV | 1 | 1 | D | U | EUGENE C |  | 09-014 | 10-042 | 11-006 | 11-026 | 12-054 |  |  |  |  |  |  |  |  |  |  |  |  | 25211208 | 13-007 | PE | 13-015 | PR |  | 2633.28 |  |  |  |  |  |  |
| 25211217 | Cooling system assembly FY13 | 20d | 2013-09-03 A | 2013-12-02 | 9-130M FS+228d |  | 20d | 2013-10-01 | 2013-10-28 | 204d | 25d | 8/5 M-F w/JLAB Holidays ReBaseline | MECH ENG [6.98 h]; MECH TECH [34.92 h]; SCIENTIST [3.49 h] | 2,436.65 | 1,639.23 |  | 0 | CHUDAKOV | 1 | 1 | D | S | EUGENE C | ST | 09-014 | 10-042 | 11-006 | 11-026 | 12-054 |  |  |  |  |  |  |  |  |  |  |  |  | 25211217 | 13-007 | EJ | 13-015 | PR |  |  |  |  |  |  |  |  |
| 25211217a | Cooling system assembly FY14 | 43d | 2013-09-03 A | 2013-12-02 | 25211217 FS-45d |  | 20d | 2013-10-29 | 2014-01-09 | 204d |  | 8/5 M-F w/JLAB Holidays ReBaseline | MECH ENG [15.02 h]; MECH TECH [75.08 h]; SCIENTIST [7.51 h] | 5,238.27 | 3,523.99 |  | 0 | CHUDAKOV | 1 | 1 | D | S | EUGENE C | ST | 09-014 | 10-042 | 11-006 | 11-026 | 12-054 |  |  |  |  |  |  |  |  |  |  |  |  | 25211217 | 13-007 | EJ | 13-015 | PR | 14-001 |  |  |  |  |  |  |  |
| 25211220 | Final Testing (FWD Chambers) | 20d | 2013-09-03 A | 2013-09-23 A | 25211175 FS-30d, 25211175a FS-30d | 100% |  | 2013-10-01 | 2013-10-28 |  |  | 8/5 M-F w/JLAB Holidays ReBaseline | MECH TECH [14 h]; SCIENTIST [56 h] | 4,872.56 | 4,722.2 |  | 0 | CHUDAKOV | 1 | 1 | D | U | EUGENE C |  |  | 10-042 | 11-006 | 11-026 | 12-054 |  | 09-012 |  |  |  |  |  |  |  |  |  |  | 25211220 | 13-007 | PE | 13-015 | PR |  | 4722.2 |  |  |  |  |  |  |
| 25211250 | Disassembly of the construction equipment and site - labor and forklift lease | 20d | 2013-09-03 A | 2013-09-23 A | 25211208 FS-20d | 100% |  | 2013-10-01 | 2013-10-28 |  |  | 8/5 M-F w/JLAB Holidays ReBaseline | SUPPLIES & MATERIALS; SCIENTIST [10 h]; MECH ENG [10 h]; MECH TECH [80 h] | 5,704.1 | 5,121 |  | 0 | CHUDAKOV | 1 | 1 | D | U | EUGENE C |  | 09-014 | 10-042 | 11-006 | 11-026 | 12-054 |  |  |  |  |  |  |  |  |  |  |  |  | 25211250 | 13-007 | EJ | 13-015 | PR |  | 5541 | EJ |  |  |  |  |  |
| 25211255LOE | Pick-up Truck Lease | 139d | 2013-09-03 A | 2014-03-31 | 25211208 FS-20d | 31% | 96d | 2013-10-01 | 2014-04-28 | 128d |  | 8/5 M-F w/JLAB Holidays ReBaseline | PROCUREMENT<$50K 60 NO ESCALATION FY14 | 2,604.93 |  |  | 431.115915 | CHUDAKOV | 1 | 1 | D | E | EUGENE C |  | 09-014 | 10-042 | 11-006 | 11-026 | 12-054 |  |  |  | 1798.964658 | 805.965342 | 80596.5342 | 100 |  |  |  |  |  | 25211250 | 13-007 | EJ | 13-015 | PR |  | 374.849427 | EJ | 69.0647482 | 30.93525179 | 100 | 100 | OB |
| 25211255LOE5 | Blue Crab Cleaning (Previously Obligated) | 20d | 2013-09-03 A | 2013-09-30 A | 25211208 FS-20d | 100% |  | 2013-10-01 | 2013-10-28 |  |  | 8/5 M-F w/JLAB Holidays ReBaseline | PROCUREMENT<$50K 60 | 153.5 |  |  | 0 | CHUDAKOV | 1 | 1 | D | E | EUGENE C |  | 09-014 | 10-042 | 11-006 | 11-026 | 12-054 |  |  |  | 0 | 153.5 | 15350 | 100 |  |  |  |  |  | 25211250 | 13-007 | EJ | 13-015 | PR |  | 153.5 | EJ | 100 | 0 | 100 | 100 | OB |
| 25211260 | Develop algorithm for fADC125 readout FY13 | 20d | 2013-09-03 A | 2014-01-17 | 9-130M FS+228d | 20% | 46d | 2013-10-01 | 2013-10-28 | 178d | 29d | 8/5 M-F w/JLAB Holidays ReBaseline | SCIENTIST [80.9 h] | 6,082.06 | 2,896.35 |  | 0 | CHUDAKOV | 1 | 1 | D | S | EUGENE C | ST | 09-014 | 10-042 | 11-006 | 11-026 | 12-054 |  |  |  |  |  |  |  |  |  |  |  |  | 25211260 | 13-007 | PE | 13-015 | PR |  | 1178.8748 |  |  |  |  |  |  |
| 25211260a | Develop algorithm for fADC125 readout FY14 | 69d | 2013-09-03 A | 2014-01-17 | 25211260 FS-75d | 20% | 46d | 2013-10-29 | 2014-02-17 | 178d |  | 8/5 M-F w/JLAB Holidays ReBaseline | SCIENTIST [279.1 h] | 20,982.74 | 9,992.22 |  | 0 | CHUDAKOV | 1 | 1 | D | S | EUGENE C | ST | 09-014 | 10-042 | 11-006 | 11-026 | 12-054 |  |  |  |  |  |  |  |  |  |  |  |  | 25211260 | 13-007 | PE | 13-015 | PR | 14-001 | 4196.5476 |  |  |  |  |  |  |

Notes:
- 15211200: Steps: Bond Cathode Foil to frames (done); Bond Ground plane (done); Bond PCB's to wire plane (done); Install Rigid flex (done); String wires on anode plane (done); Mount chamber electronics (done); Assemble Gas spacer (done); assemble single cell (done); Test cell (done)
- 15211160: Steps: Install Preamp cards (done); Install Cooling (done); Condition with gas (done); Electrical tests (done); Resolution checks (done)
- 15211205: Steps: Bond Cathode Foil to frames (done); Bond Ground plane (done); Bond PCB's to wire plane (done); Install Rigid flex (done); String wires on anode plane (done); Mount chamber electronics (done); Assemble Gas spacer (done); assemble single cell (done); Test cell (done)
- 15211165: Steps: Install Preamp cards (done); Install Cooling (done); Condition with gas (done); Electrical tests (done); Resolution checks (done)
- 15211210: Steps: Bond Cathode Foil to frames (done); Bond Ground plane (done); Bond PCB's to wire plane (done); Install Rigid flex (done); String wires on anode plane (done); Mount chamber electronics (done); Assemble Gas spacer (done); assemble single cell (done); Test cell (done)
- 15211175: Steps: Manufacturing of the spacers between the packages (done); Installation of the fiducial holders (done); Installation of the spacers between the packages (done); Installation of the cooling system connections (done); Installation of the gas connections on the packages (done)
- 25211172: Steps: __Software_development_for_strip_resolution_ (done); __Strip_resolution_studies_of_the_full_planes (done); __Software_development_for_wire_resolution_; __Wire_resolution_studies_of_the_full_planes
- 25211172a: Steps: __Software_development_for_strip_resolution_ (done); __Strip_resolution_studies_of_the_full_planes (done); __Software_development_for_wire_resolution_; __Wire_resolution_studies_of_the_full_planes
- 25211175: Steps: Installation of the cooling system connections (done); Installation of the gas connections on the packages (done)
- 25211175a: Steps: Installation of the cooling system connections (done); Installation of the gas connections on the packages (done)
- 25211217: Steps: Hard piping in the Hall; Connect chiller in the Hall
- 25211217a: Steps: Hard piping in the Hall; Connect chiller in the Hall
- 25211260: Steps: Waveform readout and processing in VME CPU (done); Optimization of the VME CPU method; Mapping the algorithm to the FPGA capabilities; Simulating the FPGA method; Study of the timing and positioning resolution
- 25211260a: Steps: Waveform readout and processing in VME CPU (done); Optimization of the VME CPU method; Mapping the algorithm to the FPGA capabilities; Simulating the FPGA method; Study of the timing and positioning resolution

| ID | WBS | Activity | Duration | Start | Finish | Predecessors | Complete | Remaining | Planned start | Planned finish | Total float | Free float | Calendar | Resources | Cost | Actual cost | LOE Divider | LOE Multiplier | Calculated Remaining Total Cost | MONTHLY EV COST | RESP - Responsibility | STRT%COMP for CM EVM | FNSH%COMP for CM EVM | HALL D Related Milestones | CR 07-024 | EVMS Reporting Codes | CAM RESPONSIBLE | CR 08-058 | CR 11-006 | CR 11-026 | CR 12-054 | Remaining Material Cost Based on % Compl | Claimed Material Cost Based on % Complet | Initial Claimed Material Calc | Claimed Material Divider | Advance Purchase Plan > 500K | CR 09-012 | CR 10-007 | 12 GeV 2nd level Critical Path | Activities with Steps | CR 09-014 | CR 09-027 | CR 09-027 Repair | CR 10-042 | CR 11-001 | LOE % Pre Calc | LOE % | CR 09-046 | Specification | CR 12-055 | CR 10-024 | MARCH!!! | ReBaseline Actuals Adjustment | Original Activity ID Rebaseline | PRIOR MONTH EV COST | CR 13-007 | BOE Labor | CR 13-015 | Post Rebaseline | CR 14-001 |
| --- | --- | --- | --- | --- | --- | --- | --- | --- | --- | --- | --- | --- | --- | --- | --- | --- | --- | --- | --- | --- | --- | --- | --- | --- | --- | --- | --- | --- | --- | --- | --- | --- | --- | --- | --- | --- | --- | --- | --- | --- | --- | --- | --- | --- | --- | --- | --- | --- | --- | --- | --- | --- | --- | --- | --- | --- | --- | --- | --- | --- |
|  | 2 | **1.5.2.1.2 CENTRAL CHAMBERS** |  | 2009-01-02 | 2014-04-21 |  |  |  |  |  |  |  |  |  |  |  |  |  |  |  |  |  |  |  |  |  |  |  |  |  |  |  |  |  |  |  |  |  |  |  |  |  |  |  |  |  |  |  |  |  |  |  |  |  |  |  |  |  |  |  |
| 15212009E |  | FY09 Travel (CENT CHAMB) | 189d | 2009-01-02 A | 2009-09-30 A | 15212009EX | 100% |  |  |  |  |  |  | TRAVEL | 982.69 |  | 100 | 100 | 0 | 982.69 | CHUDAKOV | 1 | 1 | D | 07-024 | E | EUGENE C | 08-058 | 11-006 | 11-026 | 12-054F |  |  |  |  |  |  |  |  |  |  |  |  |  |  |  |  |  |  |  |  |  |  |  |  |  |  |  |  |  |
| 15212010 |  | Proc Wire (CENT CHAMB) | 256d | 2009-02-09 A | 2010-02-19 A | 9-090M FS+60d, 12321018M | 100% |  |  |  |  |  |  | PROCUREMENT<$50K 60 | 21,296.35 |  |  |  | 0 | 21296.3522 | CHUDAKOV | 1 | 1 | D |  | D | EUGENE C |  | 11-006 | 11-026 | 12-054F | 0 | 21296.3522 | 2129635.22 | 100 | APP | 09-012 |  |  |  |  |  |  |  |  |  |  |  |  |  |  |  |  |  |  |  |  |  |  |  |
| 15212025 |  | Proc HV Cables (CENT CHAMB) | 19d | 2009-04-01 A | 2009-04-27 A | 9-100M FS+60d | 100% |  |  |  |  |  |  | PROCUREMENT<$50K 60 | 12,251.46 |  |  |  | 0 | 12251.459768 | CHUDAKOV | 1 | 1 | D |  | H | EUGENE C |  | 11-006 | 11-026 | 12-054F | 0 | 12251.459768 | 1225145.9768 | 100 | APP | 09-012 | 10-007 |  |  |  |  |  |  |  |  |  |  |  |  |  |  |  |  |  |  |  |  |  |  |
| 15212000a |  | Prepare Procurements/Fabrication Packages 2009 (CENT CHAMB) | 80d | 2009-07-03 A | 2009-10-26 A | 9-090M FS+162d | 100% |  | 2009-07-06 | 2009-10-26 |  |  |  | MECH ENG [160 h]; MECH DES [480 h] | 31,477.44 | 31,477.44 |  |  | 0 | 31252.8 | CHUDAKOV | 1 | 1 | D | 07-024 | S | EUGENE C |  | 11-006 | 11-026 | 12-054F |  |  |  |  |  |  |  | 2 | ST | 09-014 | 09-027 | 09-027 |  |  |  |  |  |  |  |  |  |  |  |  |  |  |  |  |  |
| 15212015 |  | Proc Feedthroughs (CENT CHAMB) | 286d | 2009-09-01 A | 2010-10-25 A | 15212000a FS-86d, 9-090M FS+60d, 12321018M | 100% |  |  |  |  |  |  | PROCUREMENT<$50K 60 NO ESCALATION FY10; PROCUREMENT>$50K 69 NO ESCALATION FY10 | 108,611.4 |  |  |  | 0 | 108611.4 | CHUDAKOV | 1 | 1 | D |  | S | EUGENE C |  | 11-006 | 11-026 | 12-054F | 0 | 108611.4 | 10861140 | 100 | APP |  |  |  | ST |  | 09-027 | 09-027 |  |  |  |  |  |  |  |  |  |  |  |  |  |  |  |  |  |
| 15212040 |  | Proc endplates (CENT CHAMB) | 72d | 2009-09-07 A | 2009-12-21 A | 9-090M FS+60d, 15212000c FS-245d, 12321018M, 15212000d FS-245d, 15212000a FS-86d | 100% |  | 2009-09-08 | 2009-12-18 |  |  |  | PROCUREMENT<$50K 60 NO ESCALATION FY10; PROCUREMENT>$50K 69 NO ESCALATION FY10 | 63,889.06 |  |  |  | 0 | 63889.06 | CHUDAKOV | 1 | 1 | D |  | D | EUGENE C |  | 11-006 | 11-026 | 12-054F | 0 | 63889.06 | 6388906 | 100 | APP |  |  |  |  |  | 09-027 | 09-027 |  |  |  |  |  |  |  |  |  |  |  |  |  |  |  |  |  |
| 15212010E |  | FY10 Travel (CENT CHAMB) | 248d | 2009-10-01 A | 2010-09-30 A | 15212009E | 100% |  |  |  |  |  |  | TRAVEL | 1,330.62 |  | 100 | 100 | 0 | 1330.624731 | CHUDAKOV | 1 | 1 | D | 07-024 | E | EUGENE C |  | 11-006 | 11-026 | 12-054F |  |  |  |  |  |  |  |  |  |  |  |  |  |  |  |  |  |  |  |  |  |  |  |  |  |  |  |  |  |
| 15212000c |  | Support Parts Fabrication 2010 (CENT CHAMB) | 126d | 2009-10-19 A | 2010-04-26 A | 9-100M | 100% |  |  |  |  |  |  | MECH ENG [20 h]; MECH DES [40 h] | 3,126.6 | 3,126.6 |  |  | 0 | 3126.6 | CHUDAKOV | 1 | 1 | D | 07-024 | H | EUGENE C |  | 11-006 | 11-026 | 12-054F |  |  |  |  |  |  |  | 2 |  | 09-014 | 09-027 | 09-027 |  |  |  |  |  |  |  |  |  |  |  |  |  |  |  |  |  |
| 15212020 |  | Proc Crimp pins (CENT CHAMB) | 118d | 2009-11-30 A | 2010-05-24 A | 15212000a FS-86d, 12321018M, 9-090M FS+60d | 100% |  |  |  |  |  |  | PROCUREMENT>$50K 69 NO ESCALATION FY10 | 15,972.26 |  |  |  | 0 | 15972.26 | CHUDAKOV | 1 | 1 | D |  | D | EUGENE C |  | 11-006 | 11-026 | 12-054F | 0 | 15972.26 | 1597226 | 100 | APP |  |  |  |  |  | 09-027 | 09-027 |  |  |  |  |  |  |  |  |  |  |  |  |  |  |  |  |  |
| 15212095 |  | Check Wire Quality (CENT CHAMB) | 264d | 2009-11-30 A | 2010-12-23 A | 15212010 | 100% |  | 2009-11-30 | 2010-12-21 |  |  |  | PD UNIV STAFF [680 h] | 36,125.93 | 36,125.93 |  |  | 0 | 34775.2 | CHUDAKOV | 1 | 1 | D |  | H | EUGENE C |  | 11-006 | 11-026 | 12-054F |  |  |  |  |  |  | 10-007 |  |  |  |  |  |  |  |  |  |  |  |  |  |  |  |  |  |  |  |  |  |  |
| 15212100 |  | Check Feedthroughs (CENT CHAMB) | 248d | 2009-11-30 A | 2010-11-29 A | 15212015 | 100% |  |  |  |  |  |  | CONTRB UNIV LBR [800 h] |  |  |  |  |  | 0 | CHUDAKOV | 1 | 1 | D |  | Z | EUGENE C |  | 11-006 | 11-026 | 12-054F |  |  |  |  |  |  | 10-007 |  |  |  |  |  |  |  |  |  |  |  |  |  |  |  |  |  |  |  |  |  |  |
| 15212070 |  | Proc Epoxy (CENT CHAMB) (Frozen by CR10-007) | 5d | 2009-12-14 A | 2009-12-21 A | 9-090M FS+60d, 12321018M | 100% |  | 2009-12-14 | 2009-12-18 |  |  |  | PROCUREMENT<$50K 60 | 5,324.09 |  |  |  | 0 | 5324.08805 | CHUDAKOV | 1 | 1 | D |  | H | EUGENE C |  |  |  |  | 0 | 5324.08805 | 532408.805 | 100 | APP |  | 10-007 |  |  |  |  |  |  |  |  |  |  |  |  |  |  |  |  |  |  |  |  |  |  |
| 15212075 |  | Reverse Entry per CR10-007 | 5d | 2009-12-14 A | 2009-12-21 A | 9-100M FS+41d | 100% |  | 2009-12-14 | 2009-12-18 |  |  |  | PROCUREMENT<$50K 60 | -5,324.09 |  |  |  |  |  | CHUDAKOV | 1 | 1 | D |  | H | EUGENE C |  |  |  |  |  |  |  | 100 | APP |  | 10-007 |  |  |  |  |  |  |  |  |  |  |  |  |  |  |  |  |  |  |  |  |  |  |
| 15212000d |  | Acceptance Checks/Documentation 2010 (CENT CHAMB) | 37d | 2009-12-21 A | 2010-02-19 A | 9-100M FS+69d | 100% |  | 2009-12-28 | 2010-02-19 |  |  |  | MECH ENG [20 h]; MECH DES [80 h] | 4,936.2 | 4,936.2 |  |  | 0 | 4936.2 | CHUDAKOV | 1 | 1 | D | 07-024 | H | EUGENE C |  | 11-006 | 11-026 | 12-054F |  |  |  |  |  |  |  | 2 |  | 09-014 | 09-027 | 09-027 |  |  |  |  |  |  |  |  |  |  |  |  |  |  |  |  |  |
| 15212080 |  | Proc First Article Preamps (CENT CHAMB) | 94d | 2010-01-11 A | 2010-05-24 A | 9-100M FS+60d | 100% |  |  |  |  |  |  | PROCUREMENT<$50K 60 | 6,922.35 |  |  |  | 0 | 6922.35 | CHUDAKOV | 1 | 1 | D |  | D | EUGENE C |  | 11-006 | 11-026 | 12-054F | 0 | 6922.35 | 692235 | 100 | APP |  |  |  |  |  |  |  | 10-042 |  |  |  |  |  |  |  |  |  |  |  |  |  |  |  |  |
| 15212050 |  | Proc Stand-offs (CENT CHAMB) | 27d | 2010-01-18 A | 2010-02-25 A | 12321018M, 15212000a FS-86d, 9-090M FS+60d | 100% |  | 2010-01-19 | 2010-02-25 |  |  |  | PROCUREMENT<$50K 60 | 5,324.09 |  |  |  | 0 | 5324.08805 | CHUDAKOV | 1 | 1 | D |  | D | EUGENE C |  | 11-006 | 11-026 | 12-054F | 0 | 5324.08805 | 532408.805 | 100 | APP |  | 10-007 |  |  |  | 09-027 | 09-027 |  |  |  |  |  |  |  |  |  |  |  |  |  |  |  |  |  |
| 15212001 |  | FY10 Engineering Support for Assembly Prep (CENT CHAMB) | 84d | 2010-02-01 A | 2010-05-28 A | 9-100M FS+79d | 100% |  |  |  |  |  |  | MECH ENG [40 h]; MECH DES [40 h] | 4,443.6 | 4,443.6 |  |  | 0 | 4443.6 | CHUDAKOV | 1 | 1 | D | 07-024 | H | EUGENE C |  | 11-006 | 11-026 | 12-054F |  |  |  |  |  |  |  |  |  |  | 09-027 | 09-027 |  |  |  |  |  |  |  |  |  |  |  |  |  |  |  |  |  |
| 15212110 |  | Check endplates (CENT CHAMB) | 60d | 2010-02-01 A | 2010-04-26 A | 15212040 | 100% |  |  |  |  |  |  | PD UNIV STAFF [800 h] | 42,216 | 42,216 |  |  | 0 | 42216 | CHUDAKOV | 1 | 1 | D |  | H | EUGENE C |  | 11-006 | 11-026 | 12-054F |  |  |  |  |  |  |  |  |  |  | 09-027 | 09-027 |  |  |  |  |  |  |  |  |  |  |  |  |  |  |  |  |  |
| 15212005 |  | Proc Straws (CENT CHAMB) | 322d | 2010-02-08 A | 2011-05-23 A | 12321018M, 9-090M FS+60d | 100% |  |  |  |  |  |  | PROCUREMENT>$50K 69; PROCUREMENT<$50K 60 | 67,083.51 |  |  |  | 0 | 67083.51 | CHUDAKOV | 1 | 1 | D |  | D | EUGENE C |  | 11-006 | 11-026 | 12-054F | 0 | 67083.51 | 6708351 | 100 | APP |  |  |  |  |  |  |  |  |  |  |  |  |  |  |  |  |  |  |  |  |  |  |  |  |
| 15212120 |  | Clean endplates & Compnts (CENT CHAMB) | 9d | 2010-02-09 A | 2010-02-22 A | 15212110, 15212001 FS-113d | 100% |  |  |  |  |  |  | PD UNIV STUDNT [400 h] | 4,008 | 4,008 |  |  | 0 | 4008 | CHUDAKOV | 1 | 1 | D |  | H | EUGENE C |  | 11-006 | 11-026 | 12-054F |  |  |  |  |  |  | 10-007 |  |  |  | 09-027 | 09-027 |  |  |  |  |  |  |  |  |  |  |  |  |  |  |  |  |  |
| 15212035 |  | Proc Gas Connectors (CENT CHAMB) | 431d | 2010-04-19 A | 2012-01-16 A | 9-100M FS+60d | 100% |  | 2010-04-19 | 2012-01-13 |  |  |  | PROCUREMENT<$50K 60; PROCUREMENT>$50K 69 | 71,421.04 |  |  |  | 0 | 71421.039166 | CHUDAKOV | 1 | 1 | D |  | D | EUGENE C |  | 11-006 | 11-026 | 12-054F | 0 | 71421.039166 | 7142103.9166 | 100 | APP |  |  |  |  |  |  |  | 10-042 |  |  |  |  |  |  |  |  |  |  |  |  |  |  |  |  |
| 15212030 |  | Proc Signal Cables (CENT CHAMB) | 280d | 2010-05-17 A | 2011-06-30 A | 9-100M FS+151d | 100% |  |  |  |  |  |  | PROCUREMENT<$50K 60 NO ESCALATION FY11 | 33,084.43 |  |  |  | 0 | 33084.43 | CHUDAKOV | 1 | 1 | D |  | D | EUGENE C |  | 11-006 | 11-026 | 12-054F | 0 | 33084.43 | 3308443 | 100 | APP |  | 10-007 |  |  |  |  |  | 10-042 |  |  |  |  |  |  |  |  |  |  |  |  |  |  |  |  |
| 15212060 |  | Proc Fiber Glass shell (inner surface) (CENT CHAMB) | 44d | 2010-05-24 A | 2010-07-26 A | 9-110M FS+60d | 100% |  |  |  |  |  |  | PROCUREMENT<$50K 60 | 566.92 |  |  |  | 0 | 566.92 | CHUDAKOV | 1 | 1 | D |  | H | EUGENE C |  | 11-006 | 11-026 | 12-054F | 0 | 566.92 | 56692 | 100 | APP |  |  |  |  |  |  |  |  |  |  |  |  |  |  |  |  |  |  |  |  |  |  |  |  |
| 15212105 |  | Check Crimp pins (CENT CHAMB) | 25d | 2010-06-21 A | 2010-07-26 A | 15212020 | 100% |  |  |  |  |  |  | CONTRB UNIV LBR [800 h] |  |  |  |  |  | 0 | CHUDAKOV | 1 | 1 | D |  | Z | EUGENE C |  | 11-006 | 11-026 | 12-054F |  |  |  |  |  |  | 10-007 |  |  |  |  |  |  |  |  |  |  |  |  |  |  |  |  |  |  |  |  |  |  |
| 15212002 |  | FY10 Engineering Support for Straw Tube Install (CENT CHAMB) FY10 | 53d | 2010-07-19 A | 2010-09-30 A | 15212001 | 100% |  |  |  |  |  |  | MECH ENG [17.23 h]; MECH DES [34.46 h] | 2,693.57 | 2,693.57 |  |  | 0 | 2693.5659 | CHUDAKOV | 1 | 1 | D | 07-024 | H | EUGENE C |  | 11-006 | 11-026 | 12-054F |  |  |  |  |  |  | 10-007 |  |  |  | 09-027 | 09-027 |  | 11-001 |  |  |  |  |  |  |  |  |  |  |  |  |  |  |  |
| 15212002a |  | FY10 Engineering Support for Straw Tube Install (CENT CHAMB) FY11 | 53d | 2010-07-19 A | 2010-09-30 A | 15212002 | 100% |  |  |  |  |  |  | MECH ENG [22.77 h]; MECH DES [45.54 h] | 3,559.63 | 3,559.63 |  |  | 0 | 3673.0287 | CHUDAKOV | 1 | 1 | D | 07-024 | H | EUGENE C |  | 11-006 | 11-026 | 12-054F |  |  |  |  |  |  | 10-007 |  |  |  | 09-027 | 09-027 |  | 11-001 |  |  |  |  |  |  |  |  |  |  |  |  |  |  |  |
| 15212090 |  | Test Straws (CENT CHAMB) | 232d | 2010-07-26 A | 2011-06-30 A | 15212005 FS-70d | 100% |  |  |  |  |  |  | CONTRB UNIV LBR [800 h] |  |  |  |  |  | 0 | CHUDAKOV | 1 | 1 | D |  | Z | EUGENE C |  | 11-006 | 11-026 | 12-054F |  |  |  |  |  |  | 10-007 |  |  |  |  |  |  |  |  |  |  |  |  |  |  |  |  |  |  |  |  |  |  |
| 15212003 |  | FY11 Engineering Support for Assembly Initial (CENT CHAMB) | 59d | 2010-10-01 A | 2010-12-31 A | 9-110M | 100% |  |  |  |  |  |  | MECH DES [45.39 h]; MECH ENG [5.67 h] | 2,504.09 | 2,504.09 | 100 | 100 | 0 | 2504.0817 | CHUDAKOV | 1 | 1 | D | 07-024 | E | EUGENE C |  | 11-006 | 11-026 | 12-054F |  |  |  |  |  |  |  |  |  |  | 09-027 | 09-027 |  |  |  |  |  |  |  |  |  |  |  |  |  |  |  |  |  |
| 15212011E |  | FY11 Travel (CENT CHAMB) | 248d | 2010-10-01 A | 2011-09-30 A | 15212010E | 100% |  |  |  |  |  |  | TRAVEL | 1,373.07 |  | 100 | 100 | 0 | 1373.07 | CHUDAKOV | 1 | 1 | D | 07-024 | E | EUGENE C |  | 11-006 | 11-026 | 12-054F |  |  |  |  |  |  |  |  |  |  |  |  |  |  | 8.46774193 | 91.53225806 |  |  |  |  |  |  |  |  |  |  |  |  |  |
| 15212003a |  | FY11 Engineering Support for Assembly Final (CENT CHAMB) | 189d | 2011-01-04 A | 2011-09-30 A | 15212003 | 100% |  |  |  |  |  |  | MECH ENG [160 h]; SCIENTIST [120 h]; MECH DES [680 h] | 50,826 | 50,826 | 100 | 100 | 0 | 50826 | CHUDAKOV | 1 | 1 | D | 07-024 | E | EUGENE C |  | 11-006 | 11-026 | 12-054F |  |  |  |  |  |  |  |  |  |  | 09-027 | 09-027 |  |  | 11.11111111 | 88.88888888 |  |  |  |  |  |  |  |  |  |  |  |  |  |
| 15212065 |  | Proc Lucite and hardware (Gas plenum) (CENT CHAMB) | 190d | 2011-03-01 A | 2011-11-28 A | 9-110M FS+97d | 100% |  |  |  |  |  |  | PROCUREMENT<$50K 60 | 19,900 |  |  |  | 0 | 19900 | CHUDAKOV | 1 | 1 | D |  | D | EUGENE C |  | 11-006 | 11-026 | 12-054F | 0 | 19900 | 1990000 | 100 | APP |  | 10-007 |  |  |  |  |  |  |  |  |  |  |  |  |  |  |  |  |  |  |  |  |  |  |
| 15212055 |  | Proc Aluminum shell (Outer surface) (CENT CHAMB) | 21d | 2011-04-01 A | 2011-04-30 A | 9-110M FS+162d | 100% |  | 2011-04-01 | 2011-04-29 |  |  |  | PROCUREMENT<$50K 60 | 3,401.5 |  |  |  | 0 | 3401.5 | CHUDAKOV | 1 | 1 | D |  | H | EUGENE C |  | 11-006 | 11-026 | 12-054F | 0 | 3401.5 | 340150 | 100 | APP |  |  |  |  |  |  |  |  |  |  |  |  |  |  |  |  |  |  |  |  |  |  |  |  |
| 15212088 |  | Proc Rail Bearings (CENT CHAMB) | 63d | 2011-04-02 A | 2011-06-30 A | 9-110M FS+97d | 100% |  | 2011-04-04 | 2011-06-30 |  |  |  | PROCUREMENT<$50K 60 | 2,267.68 |  |  |  | 0 | 2267.68 | CHUDAKOV | 1 | 1 | D |  | H | EUGENE C |  | 11-006 | 11-026 | 12-054F | 0 | 2267.68 | 226768 | 100 | APP |  | 10-007 |  |  |  |  |  |  |  |  |  |  |  |  |  |  |  |  |  |  |  |  |  |  |
| 15212045 |  | Prepare Procurement Packages for Supprt Frame (CENT CHAMB) | 263d | 2011-04-25 A | 2012-05-14 A | 12321018M, 15212000a FS-86d | 100% |  |  |  |  |  |  | MECH DES [320 h]; MECH ENG [160 h] | 26,282.69 | 26,282.69 |  |  | 0 | 25809.6 | CHUDAKOV | 1 | 1 | D |  | H | EUGENE C |  | 11-006 | 11-026 | 12-054F |  |  |  |  | APP |  |  |  |  |  | 09-027 | 09-027 | 10-042 |  |  |  | 09-046 |  |  |  |  |  |  |  |  |  |  |  |  |
| 15212160 |  | Attach shell (CENT CHAMB) | 37d | 2011-09-01 A | 2011-10-24 A | 15212155 FS-150d, 15212004a FS-390d, 15212055, 15212060 | 100% |  |  |  |  |  |  | CONTRB UNIV LBR [800 h] |  |  |  |  |  | 0 | CHUDAKOV | 1 | 1 | D |  | Z | EUGENE C |  | 11-006 | 11-026 | 12-054F |  |  |  |  |  |  | 10-007 |  |  |  | 09-027 | 09-027 |  |  |  |  |  |  |  |  |  |  |  |  |  |  |  |  |  |
| 15212004 |  | FY12 Engineering Support for Assembly (CENT CHAMB) | 247d | 2011-10-03 A | 2012-09-28 A | 9-120M | 100% |  |  |  |  |  |  | SCIENTIST [120 h]; MECH ENG [160 h]; MECH DES [480 h] | 42,814 | 42,814 | 100 | 100 | 0 | 42814 | CHUDAKOV | 1 | 1 | D | 07-024 | E | EUGENE C |  | 11-006 | 11-026 | 12-054F |  |  |  |  |  |  |  |  |  |  | 09-027 | 09-027 |  |  | 7.69230769 | 92.3076923 |  |  |  |  |  |  |  |  |  |  |  |  |  |
| 15212012E |  | FY12 Travel (CENT CHAMB) | 247d | 2011-10-03 A | 2012-09-28 A | 15212011E | 100% |  |  |  |  |  |  | TRAVEL | 1,418.05 |  | 100 | 100 | 0 | 1418.05 | CHUDAKOV | 1 | 1 | D | 07-024 | E | EUGENE C |  | 11-006 | 11-026 | 12-054F |  |  |  |  |  |  |  |  |  |  |  |  |  |  | 7.69230769 | 92.3076923 |  |  |  |  |  |  |  |  |  |  |  |  |  |
| 15212047 |  | Proc Supprt Frame (CENT CHAMB) Part A | 211d | 2012-01-16 A | 2012-11-12 A | 9-120M FS+21d, 15212045 FS-25d | 100% |  | 2012-01-17 | 2012-11-12 |  |  |  | PROCUREMENT<$50K 60 | 24,876 |  |  |  | 0 | 24876 | CHUDAKOV | 1 | 1 | D |  | D | EUGENE C |  | 11-006 | 11-026 | 12-054F | 0 | 24876 | 2487600 | 100 | APP |  |  |  |  |  | 09-027 | 09-027 | 10-042 |  |  |  | 09-046 | 15212047 | 12-055 |  |  |  |  |  |  |  |  |  |  |
| 15212115 |  | Test On-Chamb Electrnc's (CENT CHAMB) | 33d | 2012-02-01 A | 2012-03-19 A | 1546180, 15212080 FS+193d | 100% |  |  |  |  |  |  | SCIENTIST [160 h]; CONTRB UNIV LBR [280 h]; PD UNIV STUDNT [192 h] | 13,346.24 | 13,346.24 |  |  | 0 | 13346.24 | CHUDAKOV | 1 | 1 | D |  | H | EUGENE C |  | 11-006 | 11-026 | 12-054F |  |  |  |  |  |  | 10-007 |  |  |  | 09-027 | 09-027 | 10-042 |  |  |  |  |  |  | 10-024 |  |  |  |  |  |  |  |  |  |
| 15212145 |  | Gas Sys Installtn (CENT CHAMB) | 31d | 2012-03-03 A | 2012-04-16 A | 15212120, 15212095, 15212050, 15212035, 9-120M FS+121d, 15212090, 15212100, 15212003a FS-104d, 15212002a | 100% |  | 2012-03-05 | 2012-04-16 |  |  |  |  |  |  |  |  |  | 0 | CHUDAKOV | 1 | 1 | D |  | Z | EUGENE C |  | 11-006 | 11-026 | 12-054F |  |  |  |  |  |  | 10-007 |  |  |  | 09-027 | 09-027 |  |  |  |  |  |  |  |  |  |  |  |  |  |  |  |  |  |
| 15212087 |  | Alignment CC (CENT CHAMB) | 46d | 2012-03-12 A | 2012-05-14 A | 15212088, 9-120M, 15212160, 15212065 | 100% |  |  |  |  |  |  | PROCUREMENT<$50K 60 | 7,020.05 |  |  |  | 0 | 7020.05 | CHUDAKOV | 1 | 1 | D |  | H | EUGENE C |  | 11-006 | 11-026 | 12-054F | 0 | 7020.05 | 702005 | 100 | APP |  | 10-007 |  |  |  |  |  |  |  |  |  |  |  |  |  |  |  |  |  |  |  |  |  |  |
| 15212155 |  | Mount Signal Connectors (CENT CHAMB) | 10d | 2012-05-01 A | 2012-05-14 A | 15212004a FS-299d, 15212030, 15212105, 15212145, 15212025, 15212115 | 100% |  |  |  |  |  |  | PD UNIV STUDNT [400 h] | 4,268 | 4,268 |  |  | 0 | 4268 | CHUDAKOV | 1 | 1 | D |  | H | EUGENE C |  | 11-006 | 11-026 | 12-054F |  |  |  |  |  |  | 10-007 |  |  |  | 09-027 | 09-027 |  |  |  |  |  |  |  |  |  |  |  |  |  |  |  |  |  |
| 15212004a |  | FY13 Engineering Support for Assembly (CENT CHAMB) | 143d | 2012-10-01 A | 2013-05-01 A | 15212004 | 100% |  |  |  |  |  |  | MECH ENG [160 h]; MECH DES [240 h]; SCIENTIST [120 h] | 32,251.2 | 32,251.2 | 100 | 100 | 0 | 32251.2 | CHUDAKOV | 1 | 1 | D | 07-024 | E | EUGENE C |  | 11-006 | 11-026 | 12-054F |  |  |  |  |  |  |  |  |  |  | 09-027 | 09-027 |  |  | 0.69930069 | 99.3006993 |  |  |  |  |  |  |  |  |  |  |  |  |  |
| 15212013E |  | FY13 Travel (CENT CHAMB) | 59d | 2012-10-01 A | 2012-12-31 A | 15212012E | 100% |  |  |  |  |  |  | TRAVEL | 307.87 |  | 100 | 100 | 0 | 307.87 | CHUDAKOV | 1 | 1 | D | 07-024 | E | EUGENE C |  | 11-006 | 11-026 | 12-054F |  |  |  |  |  |  |  |  |  |  |  |  |  |  | 27.11864406 | 72.88135593 |  |  |  |  |  |  |  |  |  |  |  |  |  |
| 15212047a |  | Proc Supprt Frame (CENT CHAMB) Part B | 20d | 2012-12-03 A | 2013-01-14 A | 15212045 FS-25d, 9-120M FS+21d | 100% |  | 2013-01-02 | 2013-01-30 |  |  |  | PROCUREMENT<$50K 60 | 16,400 |  |  |  | 0 | 16400 | CHUDAKOV | 1 | 1 | D |  | D | EUGENE C |  | 11-006 | 11-026 | 12-054F | 0 | 16400 | 1640000 | 100 | APP |  |  |  |  |  | 09-027 | 09-027 | 10-042 |  |  |  | 09-046 | 15212047 | 12-055 |  | XX |  |  |  |  |  |  |  |  |
| 15212185 |  | Resolution Studies (CENT CHAMB) | 141d | 2013-08-30 A | 2013-08-30 A | 15212088, 15212160, 9-130M FS+220d | 100% |  | 2013-09-03 | 2014-04-01 |  |  |  | CONTRB UNIV LBR [800 h]; SCIENTIST [475.2 h] | 35,569.16 | 34,623.07 |  |  | 34623.072 | 34623.072 | CHUDAKOV | 1 | 1 | D |  | S | EUGENE C |  | 11-006 | 11-026 | 12-054F |  |  |  |  |  |  | 10-007 |  | ST |  |  |  |  |  |  |  |  |  |  |  |  |  |  |  |  |  |  |  |  |
| 15212190 |  | Cross talk Studies (CENT CHAMB) | 141d | 2013-08-30 A | 2013-08-30 A | 15212185 FS-141d | 100% |  | 2013-09-03 | 2014-04-01 |  |  |  | CONTRB UNIV LBR [1600 h] |  |  |  |  |  | 0 | CHUDAKOV | 1 | 1 | D |  | Z | EUGENE C |  | 11-006 | 11-026 | 12-054F |  |  |  |  |  |  |  |  |  |  |  |  |  |  |  |  |  |  |  |  |  |  |  |  |  |  |  |  |  |
| 15212195 |  | Magnetic Field Tests (CENT CHAMB) | 40d | 2013-08-30 A | 2013-08-30 A | 15212087, 15212190 FS-40d | 100% |  | 2014-02-04 | 2014-04-01 |  |  |  | CONTRB UNIV LBR [1600 h] |  |  |  |  |  | 0 | CHUDAKOV | 1 | 1 | D |  | Z | EUGENE C |  | 11-006 | 11-026 | 12-054F |  |  |  |  |  |  |  |  |  |  |  |  |  |  |  |  |  |  |  |  |  |  |  |  |  |  |  |  |  |
| 15212200 |  | Shipping (CENT CHAMB) | 1d | 2013-08-30 A | 2013-08-30 A | 15212047a, 195212260 FS-1d, 15212047 | 100% |  | 2013-10-01 | 2013-10-01 |  |  |  | PROCUREMENT<$50K 60; CONTRB UNIV LBR [1600 h] | 6,229.81 |  |  |  | 6229.81 | 6229.81 | CHUDAKOV | 1 | 1 | D |  | H | EUGENE C |  | 11-006 | 11-026 | 12-054F | 0 | 6229.81 | 622981 | 100 | APP |  |  |  |  |  |  |  |  |  |  |  | 09-046 |  |  |  |  |  |  |  |  |  |  |  |  |
| 15212205 |  | Re-Baseline Actuals Adjustment | 1d | 2013-08-30 A | 2013-08-30 A |  | 100% |  | 2013-09-03 | 2013-09-03 |  |  |  | PROCUREMENT>$50K 69 NO ESCALATION | -124,038.9 |  |  |  |  |  |  |  |  |  |  |  |  |  |  |  |  |  |  |  | 100 |  |  |  |  |  |  |  |  |  |  |  |  |  |  |  |  |  | ADJ |  |  |  |  |  |  |  |
| 25212185 |  | Resolution Studies (CENT CHAMB) FY13 | 20d | 2013-09-03 A | 2014-04-21 | 9-130M FS+228d | 30% | 111d | 2013-10-01 | 2013-10-28 | 113d | 29d | 8/5 M-F w/JLAB Holidays ReBaseline | SCIENTIST [10.39 h]; CONTRB UNIV LBR [103.9 h] | 781.12 | 214.97 |  |  |  | 113.55231 | CHUDAKOV | 1 | 1 | D |  | S | EUGENE C |  | 11-006 | 11-026 | 12-054F |  |  |  |  |  |  | 10-007 |  | ST |  |  |  |  |  |  |  |  |  |  |  |  |  | 25212185 | 113.55231 | 13-007F | PE | 13-015 | PR |  |
| 25212185a |  | Resolution Studies (CENT CHAMB) FY14 | 134d | 2013-09-03 A | 2014-04-21 | 25212185 FS-140d | 30% | 111d | 2013-10-29 | 2014-05-19 | 855d | 910d | 8/5 M-F w/JLAB Holidays ReBaseline | SCIENTIST [69.61 h]; CONTRB UNIV LBR [696.1 h] | 5,233.28 | 1,440.27 |  |  |  | 784.99197 | CHUDAKOV | 1 | 1 | D |  | S | EUGENE C |  | 11-006 | 11-026 | 12-054F |  |  |  |  |  |  | 10-007 |  | ST |  |  |  |  |  |  |  |  |  |  |  |  |  | 25212185 | 784.99197 | 13-007F | PE | 13-015 | PR | 14-001 |
| 25212010 |  | Prepare as built drawings for CDC (CENT CHAMB) | 33d | 2013-11-01 | 2013-12-19 | 2561110 FS-20d |  |  |  |  | 191d |  | 8/5 M-F w/JLAB Holidays ReBaseline | SCIENTIST [40 h]; MECH DES [200 h]; MECH ENG [24 h] | 15,059.28 |  |  |  |  | 0 | CHUDAKOV | 1 | 1 | D | 07-024 | S | EUGENE C |  | 11-006 | 11-026 | 12-054F |  |  |  |  |  |  |  |  | ST |  | 09-027 | 09-027 |  |  |  |  |  |  |  |  |  |  | 25212010 |  | 13-007F | PE | 13-015 | PR | 14-001 |

Notes:
- 15212000a: Steps: Release Drawing Package for Endplates (done); Release Drawing Package for Feedthroughs (done); Release Drawing Package for Crimp Pins (done); Obtain Budgetary Quotes for Feedthroughs and Endplates (done); Release SOW for Fab (done); Issue Purchase Reqs (done); Release Drawing Package for Standoffs (done)
- 15212015: Steps: Plastic - Complete Mold Fabrication (done); Plastic - Deliver 1st Article Parts (done); Plastic - Deliver Production Quanties (done); Aluminum - Deliver 1st Article (done); Aluminum - Deliver 1st Half of Production (done); Aluminum - Deliver Final Quanties (done)
- 15212185: Steps: Resolution Studies (CENT CHAMB) (done)
- 25212185: Steps: Detector geometrical characterization (done); Waveform readout - initial optimization (done); Cosmic tracks finding; Drift time calibration; Study of the gas mixture dependence; Corrections to the geometry; Resolution optimization
- 25212185a: Steps: Detector geometrical characterization (done); Waveform readout - initial optimization (done); Cosmic tracks finding; Drift time calibration; Study of the gas mixture dependence; Corrections to the geometry; Resolution optimization
- 25212010: Steps: Determine changes; Update 3D model; Make Drawings; Check Drawings; Release drawing package

| ID | WBS | Activity | Duration | Start | Finish | Predecessors | Complete | Remaining | Planned start | Planned finish | Total float | Free float | Calendar | Resources | Cost | Actual cost | Calculated Remaining Total Cost | MONTHLY EV COST | RESP - Responsibility | STRT%COMP for CM EVM | FNSH%COMP for CM EVM | 12 GeV 2nd level Critical Path | HALL D Related Milestones | CR 07-024 | EVMS Reporting Codes | CAM RESPONSIBLE | CR 09-014 | CR 09-027 | CR 09-027 Repair | CR 11-006 | CR 11-026 | CR 12-021 | CR 12-054 | MARCH!!! | LOE % Pre Calc | LOE % | LOE Divider | LOE Multiplier | CR 12-053 | Remaining Material Cost Based on % Compl | Claimed Material Cost Based on % Complet | Initial Claimed Material Calc | Claimed Material Divider | CR 12-034 | CR 12-055 | CR 08-016 | ReBaseline Actuals Adjustment | Original Activity ID Rebaseline | CR 13-007 | BOE Procurement | CR 13-015 | Post Rebaseline | Obligated Prior to Rebaseline | PRIOR MONTH EV COST | Activities with Steps | BOE Labor | CR 14-001 | BOE Expenses | CR 08-058 | 12 GeV 1st level Critical Path | CIVIL CRITICAL MILESTONES | 12 GeV 5th level Critical Path | Advance Purchase Plan > 500K | CR 09-004 | 12 GEV MAJOR PROCUREMENT CATAGORY | CR 09-043 | CR 09-012 | CR 09-052 | CR 10-001 | CR 10-024 |
| --- | --- | --- | --- | --- | --- | --- | --- | --- | --- | --- | --- | --- | --- | --- | --- | --- | --- | --- | --- | --- | --- | --- | --- | --- | --- | --- | --- | --- | --- | --- | --- | --- | --- | --- | --- | --- | --- | --- | --- | --- | --- | --- | --- | --- | --- | --- | --- | --- | --- | --- | --- | --- | --- | --- | --- | --- | --- | --- | --- | --- | --- | --- | --- | --- | --- | --- | --- | --- | --- | --- |
|  | 3 | **1.5.2.1.3 START COUNTERS** |  | 2011-12-01 | 2014-02-27 |  |  |  |  |  |  |  |  |  |  |  |  |  |  |  |  |  |  |  |  |  |  |  |  |  |  |  |  |  |  |  |  |  |  |  |  |  |  |  |  |  |  |  |  |  |  |  |  |  |  |  |  |  |  |  |  |  |  |  |  |  |  |  |  |  |
| 15213000 |  | Prepare Fabrication Packages (START COUNTERS) | 297d | 2011-12-01 A | 2013-02-11 A | 9-120M FS+41d | 100% |  | 2011-12-01 | 2013-02-15 |  |  |  | MECH ENG [40 h]; MECH DES [400 h] | 22,288.99 | 22,282.31 | 0 | 22072.8 | CHUDAKOV | 1 | 1 | 2 | D | 07-024 | H | EUGENE C | 09-014 | 09-027 | 09-027 | 11-006 | 11-026 | 12-021F | 12-054F | XX |  |  |  |  |  |  |  |  |  |  |  |  |  |  |  |  |  |  |  |  |  |  |  |  |  |  |  |  |  |  |  |  |  |  |  |  |
| 15213001 |  | FY12 Engineering Support for Assembly (START COUNTERS) FY12 | 127d | 2012-04-02 A | 2012-09-28 A | 9-120M, 15213000 FS-100d | 100% |  |  |  |  |  |  | MECH DES [81.73 h]; MECH ENG [54.49 h] | 7,757.77 | 7,757.77 | 0 | 7757.7729 | CHUDAKOV | 1 | 1 | 2 | D | 07-024 | E | EUGENE C | 09-014 | 09-027 | 09-027 | 11-006 | 11-026 | 12-021 | 12-054F |  | 54.30107526 | 45.69892473 | 100 | 100 | 12-053 |  |  |  |  |  |  |  |  |  |  |  |  |  |  |  |  |  |  |  |  |  |  |  |  |  |  |  |  |  |  |  |
| 15213010 |  | Procure Sipms Part A | 179d | 2012-07-09 A | 2013-05-13 A | 9-130M FS-60d | 100% |  | 2012-07-09 | 2013-03-29 |  |  |  | PROCUREMENT<$50K 60 | 9,906.24 |  | 0 | 9906.24 | CHUDAKOV | 1 | 1 |  | D |  | D | EUGENE C |  |  |  |  |  | 12-021 | 12-054F |  |  |  |  |  |  | 0 | 9906.24 | 990624 | 100 | 12-034 | 12-055 |  |  |  |  |  |  |  |  |  |  |  |  |  |  |  |  |  |  |  |  |  |  |  |  |  |
| 15213001a |  | FY12 Engineering Support for Assembly (START COUNTERS) FY13 | 59d | 2012-10-01 A | 2012-12-31 A | 15213001 | 100% |  |  |  |  |  |  | MECH DES [38.27 h]; MECH ENG [25.51 h] | 3,748.3 | 3,748.3 | 0 | 3748.3053 | CHUDAKOV | 1 | 1 | 2 | D | 07-024 | E | EUGENE C | 09-014 | 09-027 | 09-027 | 11-006 | 11-026 | 12-021 | 12-054F |  | 27.11864406 | 72.88135593 | 100 | 100 | 12-053 |  |  |  |  |  |  |  |  |  |  |  |  |  |  |  |  |  |  |  |  |  |  |  |  |  |  |  |  |  |  |  |
| 15213010a |  | Procure Sipms Part B | 97d | 2013-05-01 A | 2013-05-13 A | 9-130M FS+185d | 100% |  | 2013-07-02 | 2013-11-15 |  |  |  | PROCUREMENT<$50K 60 | 21,050.76 |  | 0 | 21050.76 | CHUDAKOV | 1 | 1 |  | D |  | D | EUGENE C |  |  |  |  |  | 12-021 | 12-054F |  |  |  |  |  |  | 0 | 21050.76 | 2105076 | 100 | 12-034 | 12-055 |  |  |  |  |  |  |  |  |  |  |  |  |  |  |  |  |  |  |  |  |  |  |  |  |  |
| 15213005 |  | Fabricate Start Counter (START COUNTERS) | 141d | 2013-08-30 A | 2013-08-30 A | 15213000, 9-130M FS+163d | 100% |  | 2013-09-03 | 2014-04-01 |  |  |  | CONTRB UNIV LBR [3245.39 h]; PROCUREMENT<$50K 60 NO ESCALATION FY14 |  |  | 25547.08 | 0 | CHUDAKOV | 1 | 1 |  | D |  | H | EUGENE C | 09-014 |  |  | 11-006 | 11-026 | 12-021 | 12-054 |  |  |  |  |  |  |  |  |  |  | 12-034 |  | 08-016 |  |  |  |  |  |  |  |  |  |  |  |  |  |  |  |  |  |  |  |  |  |  |  |  |
| 15213015 |  | Re-Baseline Actuals Adjustment | 1d | 2013-08-30 A | 2013-08-30 A |  | 100% |  | 2013-09-03 | 2013-09-03 |  |  |  | PROCUREMENT>$50K 69 NO ESCALATION | -1,125.31 |  |  |  |  |  |  |  |  |  |  |  |  |  |  |  |  |  |  |  |  |  |  |  |  |  |  |  | 100 |  |  |  | ADJ |  |  |  |  |  |  |  |  |  |  |  |  |  |  |  |  |  |  |  |  |  |  |  |
| 25213005 |  | Fabricate (FIU) Start Counter (START COUNTERS) | 117d | 2013-09-03 A | 2014-02-27 | 9-130M FS+228d | 2% | 74d | 2013-10-01 | 2014-03-27 | 131d |  | 8/5 M-F w/JLAB Holidays ReBaseline | PROCUREMENT<$50K 60 NO ESCALATION FY14 | 28,432.65 |  |  | 568.653 | CHUDAKOV | 1 | 1 |  | D |  | D | EUGENE C | 09-014 |  |  | 11-006 | 11-026 | 12-021 | 12-054 |  |  |  |  |  |  | 27863.997 | 568.653 | 56865.3 | 100 | 12-034 |  | 08-016 |  | 25213005 | 13-007F | VQ | 13-015 | PR | OB |  |  |  |  |  |  |  |  |  |  |  |  |  |  |  |  |  |
| 25213015 |  | All Manufacturing Drawings for start counter FY13 | 20d | 2013-09-03 A | 2013-11-22 | 9-130M FS+228d | 18% | 16d | 2013-10-01 | 2013-10-28 | 158d | 4d | 8/5 M-F w/JLAB Holidays ReBaseline | MECH DES [27.78 h]; MECH ENG [2.78 h] | 1,632.66 | 878.92 |  | 0 | CHUDAKOV | 1 | 1 | 2 | D |  | S | EUGENE C |  |  |  |  |  |  |  |  |  |  |  |  |  |  |  |  |  |  |  |  |  | 25213015 | 13-007 |  | 13-015 | PR |  | 284.77141614 | ST | PE |  |  |  |  |  |  |  |  |  |  |  |  |  |  |
| 25213015a |  | All Manufacturing Drawings for start counter FY14 | 16d | 2013-09-03 A | 2013-11-22 | 25213015 FS-30d | 18% | 16d | 2013-10-01 | 2013-10-22 | 158d | 4d | 8/5 M-F w/JLAB Holidays ReBaseline | MECH DES [22.22 h]; MECH ENG [2.22 h] | 1,305.69 | 702.91 |  | 0 | CHUDAKOV | 1 | 1 | 2 | D |  | S | EUGENE C |  |  |  |  |  |  |  |  |  |  |  |  |  |  |  |  |  |  |  |  |  | 25213015 | 13-007 |  | 13-015 | PR |  | 235.02525966 | ST | PE | 14-001 |  |  |  |  |  |  |  |  |  |  |  |  |  |
| 25213020 |  | Procure start counter support frame parts | 67d | 2013-10-21 A | 2014-02-07 | 25213015 FS-20d, 25213015a FS-20d | 8% | 60d | 2013-11-25 | 2014-03-12 | 154d | 0d | 8/5 M-F w/JLAB Holidays ReBaseline | PROCUREMENT<$50K 60; SUPPLIES & MATERIALS | 5,262.69 |  |  | 421.0152 | CHUDAKOV | 1 | 1 | 2 | D |  | D | EUGENE C |  |  |  |  |  |  |  |  |  |  |  |  |  |  |  |  |  |  |  |  |  | 25213020 | 13-007 |  | 13-015 | PR |  |  |  |  | 14-001 | EJ |  |  |  |  |  |  |  |  |  |  |  |  |
| 25213025 |  | Assemble start counter support frame | 25d | 2014-01-03 | 2014-02-07 | 25213020 FS-25d |  |  |  |  | 154d |  | 8/5 M-F w/JLAB Holidays ReBaseline | MECH TECH [160 h]; MECH ENG [40 h] | 10,558 |  |  | 0 | CHUDAKOV | 1 | 1 | 2 | D |  | S | EUGENE C |  |  |  |  |  |  |  |  |  |  |  |  |  |  |  |  |  |  |  |  |  | 25213025 | 13-007 |  | 13-015 | PR |  |  | ST | PE | 14-001 |  |  |  |  |  |  |  |  |  |  |  |  |  |
|  | 2 | **1.5.2.2 CALORIMETRY** |  | 2009-01-02 | 2014-03-06 |  |  |  |  |  |  |  |  |  |  |  |  |  |  |  |  |  |  |  |  |  |  |  |  |  |  |  |  |  |  |  |  |  |  |  |  |  |  |  |  |  |  |  |  |  |  |  |  |  |  |  |  |  |  |  |  |  |  |  |  |  |  |  |  |  |
|  | 1 | **1.5.2.2.1 BARREL CALORIMETER** |  | 2009-01-02 | 2014-03-06 |  |  |  |  |  |  |  |  |  |  |  |  |  |  |  |  |  |  |  |  |  |  |  |  |  |  |  |  |  |  |  |  |  |  |  |  |  |  |  |  |  |  |  |  |  |  |  |  |  |  |  |  |  |  |  |  |  |  |  |  |  |  |  |  |  |
| 15221009E |  | FY09 Travel (BarCal) | 189d | 2009-01-02 A | 2009-09-30 A | 15221009EX | 100% |  |  |  |  |  |  | TRAVEL | 5,625.95 |  | 0 | 5625.95 | CHUDAKOV | 1 | 1 |  | D | 07-024 | E | EUGENE C |  |  |  | 11-006 | 11-026 |  |  |  |  |  | 100 | 100 |  |  |  |  |  |  |  |  |  |  |  |  |  |  |  |  |  |  |  |  | 08-058 |  |  |  |  |  |  |  |  |  |  |  |
| 15221010 |  | Proc SciFi Mods 01-06 (BarCal) P-1 | 107d | 2009-03-02 A | 2009-07-30 A | 123221025, 1-6M, 12322018M, 9-090M FS+41d | 100% |  |  |  |  |  |  | PROCUREMENT>$50K 69; PROCUREMENT<$50K 60 | 415,776 |  | 0 | 415776 | CHUDAKOV | 1 | 1 |  | D | 07-024 | P | EUGENE C |  |  |  | 11-006 | 11-026 | 12-021F | 12-054F |  |  |  |  |  |  | 0 | 415776 | 41577600 | 100 |  |  |  |  |  |  |  |  |  |  |  |  |  |  |  |  | 1 | CVL | 5 | APP | 09-004 | 5221A |  |  |  |  |  |
| 15221192LOE |  | Bcal Module Construction Manager Initial Prototype | 106d | 2009-04-01 A | 2009-08-28 A | 9-090M FS+120d | 100% |  |  |  |  |  |  | PD UNIV STAFF [571.8 h] | 29,241.85 | 29,241.85 | 0 | 29241.852 | CHUDAKOV | 1 | 1 |  | D |  | E | EUGENE C | 09-014 |  |  | 11-006 | 11-026 | 12-021F | 12-054F |  |  |  | 100 | 100 |  |  |  |  |  |  |  |  |  |  |  |  |  |  |  |  |  |  |  |  |  |  |  |  | APP |  | 5221B | 09-043 |  |  |  |  |
| 15221035 |  | Proc Clean Room (BarCal) | 124d | 2009-05-01 A | 2009-10-26 A | 9-090M FS+120d | 100% |  |  |  |  |  |  | PD UNIV STUDNT [320 h]; PROCUREMENT<$50K 60 | 35,066.13 | 3,121.6 | 0 | 35051.7283 | CHUDAKOV | 1 | 1 |  | D |  | D | EUGENE C | 09-014 |  |  | 11-006 | 11-026 | 12-021F | 12-054F |  |  |  |  |  |  | 0 | 31944.5283 | 3194452.83 | 100 |  |  |  |  |  |  |  |  |  |  |  |  |  |  |  |  |  |  |  | APP |  | 5221B | 09-043 |  |  |  |  |
| 15221060 |  | Proc Lead Sheets 1-6 (BarCal) | 108d | 2009-05-18 A | 2009-10-19 A | 12322018M, 9-090M FS+60d | 100% |  |  |  |  |  |  | PROCUREMENT<$50K 60 | 24,490.81 |  | 0 | 24490.80503 | CHUDAKOV | 1 | 1 |  | D |  | D | EUGENE C |  |  |  | 11-006 | 11-026 | 12-021F | 12-054F |  |  |  |  |  |  | 0 | 24490.80503 | 2449080.503 | 100 |  |  |  |  |  |  |  |  |  |  |  |  |  |  |  |  |  |  |  |  |  |  |  |  |  |  |  |
| 15221040 |  | Proc Fiber Handling & Sorting table (BarCal) | 45d | 2009-06-22 A | 2009-08-24 A | 9-090M FS+120d | 100% |  |  |  |  |  |  | PROCUREMENT<$50K 60; PD UNIV STUDNT [160 h] | 4,748.05 | 1,553.6 | 0 | 4748.05283 | CHUDAKOV | 1 | 1 |  | D |  | H | EUGENE C | 09-014 |  |  | 11-006 | 11-026 | 12-021F | 12-054F |  |  |  |  |  |  | 0 | 3194.45283 | 319445.283 | 100 |  |  |  |  |  |  |  |  |  |  |  |  |  |  |  |  |  |  |  |  |  |  | 09-043 |  |  |  |  |
| 15221012 |  | Proc SciFi Mods 25-30 (BarCal) P-2 | 62d | 2009-07-30 A | 2009-10-26 A | 15221010, 9-090M | 100% |  |  |  |  |  |  | PROCUREMENT>$50K 69; PROCUREMENT<$50K 60 | 417,480 |  | 0 | 417480 | CHUDAKOV | 1 | 1 |  | D | 07-024 | P | EUGENE C |  |  |  | 11-006 | 11-026 | 12-021F | 12-054F |  |  |  |  |  |  | 0 | 417480 | 41748000 | 100 |  |  | 08-016 |  |  |  |  |  |  |  |  |  |  |  |  |  | 1 | CVL | 5 | APP | 09-004 | 5221A |  | 09-012 | 09-052 |  |  |
| 15221001 |  | Prepare Fabrication Packages 2009 (BarCal) | 1d | 2009-08-03 A | 2009-08-03 A | 9-090M FS+163d | 100% |  |  |  |  |  |  | MECH ENG [80 h]; MECH DES [240 h] | 15,626.4 | 15,626.4 | 0 | 15626.4 | CHUDAKOV | 1 | 1 | 2 | D | 07-024 | H | EUGENE C | 09-014 | 09-027 | 09-027 | 11-006 | 11-026 | 12-021F | 12-054F |  |  |  |  |  |  |  |  |  |  |  |  |  |  |  |  |  |  |  |  |  |  |  |  |  |  |  |  |  |  |  |  |  |  |  |  |  |
| 15221185 |  | Scifi Sorting & Bundling Mods 1-6 (BarCal) (FROZEN and Reversed BY CR09-043 Activity 15221191) | 1d | 2009-08-03 A | 2009-08-03 A | 9-090M FS+180d | 100% |  |  |  |  |  |  | PD UNIV STUDNT [34.67 h] | 336.65 | 336.65 | 0 | 336.6457 | CHUDAKOV | 1 | 1 |  | D |  | H | EUGENE C | 09-014 |  |  |  |  |  |  |  |  |  |  |  |  |  |  |  |  |  |  |  |  |  |  |  |  |  |  |  |  |  |  |  |  |  |  |  |  |  |  | 09-043 |  |  |  |  |
| 15221190 |  | Lead Cutting & Swaging Mods 1-6 (BarCal) (FROZEN and Reversed BY CR09-043 Activity 15221191) | 1d | 2009-08-03 A | 2009-08-03 A | 9-090M FS+120d | 100% |  |  |  |  |  |  | PD UNIV STUDNT [1440 h] | 13,982.4 | 13,982.4 | 0 | 13982.4 | CHUDAKOV | 1 | 1 |  | D |  | H | EUGENE C | 09-014 |  |  |  |  |  |  |  |  |  |  |  |  |  |  |  |  |  |  |  |  |  |  |  |  |  |  |  |  |  |  |  |  |  |  |  |  |  |  | 09-043 |  |  |  |  |
| 15221191 |  | Reverse Entry for Frozen Activities 15221185, 15221190 and 15221310 Per CR09-043 | 1d | 2009-08-03 A | 2009-08-03 A | 9-090M FS+208d | 100% |  |  |  |  |  |  | PD UNIV STUDNT [-2098.8 h] | -20,379.35 | -20,379.35 |  |  | CHUDAKOV | 1 | 1 |  | D |  | H | EUGENE C | 09-014 |  |  |  |  |  |  |  |  |  |  |  |  |  |  |  |  |  |  |  |  |  |  |  |  |  |  |  |  |  |  |  |  |  |  |  |  |  |  | 09-043 |  |  |  |  |
| 15221310 |  | Lead Cutting & Swaging Mods 25-30 (BarCal) (FROZEN and Reversed BY CR09-043 Activity 15221191) | 1d | 2009-08-03 A | 2009-08-03 A | 9-090M FS+180d | 100% |  |  |  |  |  |  | PD UNIV STUDNT [624 h] | 6,059.04 | 6,059.04 | 0 | 6059.04 | CHUDAKOV | 1 | 1 |  | D |  | H | EUGENE C | 09-014 |  |  |  |  |  |  |  |  |  |  |  |  |  |  |  |  |  |  |  |  |  |  |  |  |  |  |  |  |  |  |  |  |  |  |  |  |  |  | 09-043 |  |  |  |  |
| 15221002 |  | Evaluate Procurements 2009 (BarCal) | 50d | 2009-08-10 A | 2009-10-19 A | 15221001 FS-25d | 100% |  |  |  |  |  |  | MECH ENG [80 h] | 5,147.23 | 5,147.23 | 0 | 5104.8 | CHUDAKOV | 1 | 1 | 2 | D | 07-024 | H | EUGENE C | 09-014 | 09-027 | 09-027 | 11-006 | 11-026 | 12-021F | 12-054F |  |  |  |  |  |  |  |  |  |  |  |  |  |  |  |  |  |  |  |  |  |  |  |  |  |  |  |  |  |  |  |  | 09-043 |  |  |  |  |
| 15221050 |  | Proc 2nd press/Frame (BarCal) | 40d | 2009-08-31 A | 2009-10-26 A | 9-090M FS+226d | 100% |  |  |  |  |  |  | PROCUREMENT<$50K 60 NO ESCALATION | 30,655 |  | 0 | 30655 | CHUDAKOV | 1 | 1 |  | D |  | S | EUGENE C | 09-014 |  |  | 11-006 | 11-026 | 12-021F | 12-054F |  |  |  |  |  |  | 0 | 30655 | 3065500 | 100 |  |  |  |  |  |  |  |  |  |  |  | ST |  |  |  |  |  |  |  | APP |  | 5221B | 09-043 |  |  | 10-001A |  |
| 15221195 |  | Bcal Module Construction Manager Phase 1 (LOE) | 120d | 2009-08-31 A | 2010-03-01 A | 15221192LOE FF | 100% |  |  |  |  |  |  | PROCUREMENT<$50K 60 NO ESCALATION; PROCUREMENT>$50K 69 NO ESCALATION | 50,160 |  | 0 | 50160 | CHUDAKOV | 1 | 1 |  | D |  | E | EUGENE C |  |  |  | 11-006 | 11-026 | 12-021F | 12-054F |  |  |  | 100 | 100 |  | 0 | 50160 | 5016000 | 100 |  |  |  |  |  |  |  |  |  |  |  |  |  |  |  |  |  |  |  | APP |  | 5221B | 09-043 |  |  | 10-001A |  |
| 15221200 |  | Module #1 Matrix Fabrication | 76d | 2009-09-01 A | 2009-12-21 A | 15221002 FS-22d, 9-090M, 15221035, 15221040 | 100% |  | 2009-09-01 | 2009-12-18 |  |  |  | PROCUREMENT>$50K 69 NO ESCALATION | 12,842 |  | 0 | 12842 | CHUDAKOV | 1 | 1 |  | D |  | P | EUGENE C |  |  |  | 11-006 | 11-026 | 12-021F | 12-054F |  |  |  |  |  |  | 0 | 12842 | 1284200 | 100 |  |  | 08-016 |  |  |  |  |  |  |  |  |  |  |  |  |  |  |  |  | APP |  | 5221B | 09-043 |  |  | 10-001A |  |
| 15221205 |  | Module #1 Machining and Shipping | 159d | 2009-09-01 A | 2010-04-26 A | 9-090M FS+226d | 100% |  |  |  |  |  |  | PROCUREMENT>$50K 69 NO ESCALATION | 4,607 |  | 0 | 4607 | CHUDAKOV | 1 | 1 |  | D |  | P | EUGENE C |  |  |  | 11-006 | 11-026 | 12-021F | 12-054F |  |  |  |  |  |  | 0 | 4607 | 460700 | 100 |  |  |  |  |  |  |  |  |  |  |  |  |  |  |  |  |  |  |  | APP |  | 5221B | 09-043 |  |  | 10-001A |  |
| 15221210 |  | Module #2 Matrix Fabrication | 90d | 2009-09-01 A | 2010-01-18 A | 9-090M FS+226d | 100% |  | 2009-09-01 | 2010-01-15 |  |  |  | PROCUREMENT>$50K 69 NO ESCALATION | 12,842 |  | 0 | 12842 | CHUDAKOV | 1 | 1 |  | D |  | P | EUGENE C |  |  |  | 11-006 | 11-026 | 12-021F | 12-054F |  |  |  |  |  |  | 0 | 12842 | 1284200 | 100 |  |  |  |  |  |  |  |  |  |  |  |  |  |  |  |  |  |  |  | APP |  | 5221B | 09-043 |  |  | 10-001A |  |
| 15221215 |  | Module #2 Machining and Shipping | 159d | 2009-09-01 A | 2010-04-26 A | 9-090M FS+226d | 100% |  |  |  |  |  |  | PROCUREMENT>$50K 69 NO ESCALATION | 4,607 |  | 0 | 4607 | CHUDAKOV | 1 | 1 |  | D |  | P | EUGENE C | 09-014 |  |  | 11-006 | 11-026 | 12-021F | 12-054F |  |  |  |  |  |  | 0 | 4607 | 460700 | 100 |  |  |  |  |  |  |  |  |  |  |  |  |  |  |  |  |  |  |  | APP |  | 5221B | 09-043 |  |  | 10-001A |  |
| 15221220 |  | Module #3 Matrix Fabrication | 107d | 2009-09-01 A | 2010-02-10 A | 9-090M FS+226d | 100% |  |  |  |  |  |  | PROCUREMENT>$50K 69 NO ESCALATION | 12,842 |  | 0 | 12842 | CHUDAKOV | 1 | 1 |  | D |  | P | EUGENE C | 09-014 |  |  | 11-006 | 11-026 | 12-021F | 12-054F |  |  |  |  |  |  | 0 | 12842 | 1284200 | 100 |  |  |  |  |  |  |  |  |  |  |  |  |  |  |  |  |  |  |  | APP |  | 5221B | 09-043 |  |  | 10-001A |  |
| 15221225 |  | Module #3 Machining and Shipping | 159d | 2009-09-01 A | 2010-04-26 A | 9-090M FS+226d | 100% |  |  |  |  |  |  | PROCUREMENT>$50K 69 NO ESCALATION | 4,607 |  | 0 | 4607 | CHUDAKOV | 1 | 1 |  | D |  | P | EUGENE C | 09-014 |  |  | 11-006 | 11-026 | 12-021F | 12-054F |  |  |  |  |  |  | 0 | 4607 | 460700 | 100 |  |  |  |  |  |  |  |  |  |  |  |  |  |  |  |  |  |  |  | APP |  | 5221B | 09-043 |  |  | 10-001A |  |
| 15221230 |  | Module #4 Matrix Fabrication | 118d | 2009-09-01 A | 2010-02-26 A | 9-090M FS+226d | 100% |  |  |  |  |  |  | PROCUREMENT>$50K 69 NO ESCALATION | 12,842 |  | 0 | 12842 | CHUDAKOV | 1 | 1 |  | D |  | P | EUGENE C | 09-014 |  |  | 11-006 | 11-026 | 12-021F | 12-054F |  |  |  |  |  |  | 0 | 12842 | 1284200 | 100 |  |  | 08-016 |  |  |  |  |  |  |  |  |  |  |  |  |  |  |  |  | APP |  | 5221B | 09-043 |  |  | 10-001A |  |
| 15221235 |  | Module #4 Machining and Shipping | 159d | 2009-09-01 A | 2010-04-26 A | 9-090M FS+226d | 100% |  |  |  |  |  |  | PROCUREMENT>$50K 69 NO ESCALATION | 4,607 |  | 0 | 4607 | CHUDAKOV | 1 | 1 |  | D |  | P | EUGENE C |  |  |  | 11-006 | 11-026 | 12-021F | 12-054F |  |  |  |  |  |  | 0 | 4607 | 460700 | 100 |  |  |  |  |  |  |  |  |  |  |  |  |  |  |  |  |  |  |  | APP |  | 5221B | 09-043 |  |  | 10-001A |  |
| 15221240 |  | Module #5 Matrix Fabrication | 129d | 2009-09-01 A | 2010-03-15 A | 15221045, 9-090M FS+226d | 100% |  |  |  |  |  |  | PROCUREMENT>$50K 69 NO ESCALATION | 12,842 |  | 0 | 12842 | CHUDAKOV | 1 | 1 |  | D |  | P | EUGENE C |  |  |  | 11-006 | 11-026 | 12-021F | 12-054F |  |  |  |  |  |  | 0 | 12842 | 1284200 | 100 |  |  |  |  |  |  |  |  |  |  |  |  |  |  |  |  |  |  |  | APP |  | 5221B | 09-043 |  |  | 10-001A |  |
| 15221245 |  | Module #5 Machining and Shipping | 203d | 2009-09-01 A | 2010-06-28 A | 9-090M FS+226d | 100% |  |  |  |  |  |  | PROCUREMENT>$50K 69 NO ESCALATION | 4,607 |  | 0 | 4607 | CHUDAKOV | 1 | 1 |  | D |  | P | EUGENE C |  |  |  | 11-006 | 11-026 | 12-021F | 12-054F |  |  |  |  |  |  | 0 | 4607 | 460700 | 100 |  |  |  |  |  |  |  |  |  |  |  |  |  |  |  |  |  |  |  | APP |  | 5221B | 09-043 |  |  | 10-001A |  |
| 15221250 |  | Module #6 Matrix Fabrication | 134d | 2009-09-01 A | 2010-03-22 A | 9-090M FS+226d | 100% |  |  |  |  |  |  | PROCUREMENT>$50K 69 NO ESCALATION | 12,842 |  | 0 | 12842 | CHUDAKOV | 1 | 1 |  | D |  | P | EUGENE C | 09-014 |  |  | 11-006 | 11-026 | 12-021F | 12-054F |  |  |  |  |  |  | 0 | 12842 | 1284200 | 100 |  |  |  |  |  |  |  |  |  |  |  |  |  |  |  |  |  |  |  | APP |  | 5221B | 09-043 |  |  | 10-001A |  |
| 15221255 |  | Module #6 Machining and Shipping | 203d | 2009-09-01 A | 2010-06-28 A | 9-090M FS+226d | 100% |  |  |  |  |  |  | PROCUREMENT>$50K 69 NO ESCALATION | 4,607 |  | 0 | 4607 | CHUDAKOV | 1 | 1 |  | D |  | P | EUGENE C | 09-014 |  |  | 11-006 | 11-026 | 12-021F | 12-054F |  |  |  |  |  |  | 0 | 4607 | 460700 | 100 |  |  |  |  |  |  |  |  |  |  |  |  |  |  |  |  |  |  |  | APP |  | 5221B | 09-043 |  |  | 10-001A |  |
| 15221260 |  | Module #7 Matrix Fabrication | 159d | 2009-09-01 A | 2010-04-26 A | 9-090M FS+226d | 100% |  |  |  |  |  |  | PROCUREMENT>$50K 69 NO ESCALATION | 12,842 |  | 0 | 12842 | CHUDAKOV | 1 | 1 |  | D |  | P | EUGENE C | 09-014 |  |  | 11-006 | 11-026 | 12-021F | 12-054F |  |  |  |  |  |  | 0 | 12842 | 1284200 | 100 |  |  |  |  |  |  |  |  |  |  |  |  |  |  |  |  |  |  |  | APP |  | 5221B | 09-043 |  |  | 10-001A |  |
| 15221265 |  | Module #7 Machining and Shipping | 203d | 2009-09-01 A | 2010-06-28 A | 9-090M FS+226d | 100% |  |  |  |  |  |  | PROCUREMENT>$50K 69 NO ESCALATION | 4,607 |  | 0 | 4607 | CHUDAKOV | 1 | 1 |  | D |  | P | EUGENE C |  |  |  | 11-006 | 11-026 | 12-021F | 12-054F |  |  |  |  |  |  | 0 | 4607 | 460700 | 100 |  |  |  |  |  |  |  |  |  |  |  |  |  |  |  |  |  |  |  | APP |  | 5221B | 09-043 |  |  | 10-001A |  |
| 15221270 |  | Module #8 Matrix Fabrication | 159d | 2009-09-01 A | 2010-04-26 A | 9-090M FS+226d | 100% |  |  |  |  |  |  | PROCUREMENT>$50K 69 NO ESCALATION | 12,842 |  | 0 | 12842 | CHUDAKOV | 1 | 1 |  | D |  | P | EUGENE C |  |  |  | 11-006 | 11-026 | 12-021F | 12-054F |  |  |  |  |  |  | 0 | 12842 | 1284200 | 100 |  |  |  |  |  |  |  |  |  |  |  |  |  |  |  |  |  |  |  | APP |  | 5221B | 09-043 |  |  | 10-001A |  |
| 15221275 |  | Module #8 Machining and Shipping | 203d | 2009-09-01 A | 2010-06-28 A | 9-090M FS+226d | 100% |  |  |  |  |  |  | PROCUREMENT>$50K 69 NO ESCALATION | 4,607 |  | 0 | 4607 | CHUDAKOV | 1 | 1 |  | D |  | P | EUGENE C |  |  |  | 11-006 | 11-026 | 12-021F | 12-054F |  |  |  |  |  |  | 0 | 4607 | 460700 | 100 |  |  |  |  |  |  |  |  |  |  |  |  |  |  |  |  |  |  |  | APP |  | 5221B | 09-043 |  |  | 10-001A |  |
| 15221014 |  | Proc SciFi Mods P-2 FY10 October Delivery | 57d | 2009-09-09 A | 2009-11-30 A | 9-090M FS+232d, 15221012 FS-16d | 100% |  |  |  |  |  |  | PROCUREMENT<$50K 60 NO ESCALATION; PROCUREMENT>$50K 69 NO ESCALATION | 103,944 |  | 0 | 103944 | CHUDAKOV | 1 | 1 |  | D | 07-024 | P | EUGENE C |  |  |  | 11-006 | 11-026 | 12-021F | 12-054F |  |  |  |  |  |  | 0 | 103944 | 10394400 | 100 |  |  |  |  |  |  |  |  |  |  |  |  |  |  |  |  | 1 | CVL |  | APP | 09-004 | 5221A |  |  | 09-052 |  |  |
| 15221016 |  | Proc SciFi Mods P-2 FY10 November Delivery | 71d | 2009-09-09 A | 2009-12-21 A | 15221014 FS-38d | 100% |  | 2009-09-09 | 2009-12-18 |  |  |  | PROCUREMENT>$50K 69 NO ESCALATION | 103,944 |  | 0 | 103944 | CHUDAKOV | 1 | 1 |  | D | 07-024 | P | EUGENE C |  |  |  | 11-006 | 11-026 | 12-021F | 12-054F |  |  |  |  |  |  | 0 | 103944 | 10394400 | 100 |  |  |  |  |  |  |  |  |  |  |  |  |  |  |  |  | 1 | CVL |  | APP | 09-004 | 5221A |  |  | 09-052 |  |  |
| 15221018 |  | Proc SciFi Mods P-2 FY10 December Delivery | 89d | 2009-09-09 A | 2010-01-22 A | 15221016 FS-57d | 100% |  |  |  |  |  |  | PROCUREMENT>$50K 69 NO ESCALATION | 103,944 |  | 0 | 103944 | CHUDAKOV | 1 | 1 |  | D | 07-024 | P | EUGENE C |  |  |  | 11-006 | 11-026 | 12-021F | 12-054F |  |  |  |  |  |  | 0 | 103944 | 10394400 | 100 |  |  | 08-016 |  |  |  |  |  |  |  |  |  |  |  |  |  | 1 |  |  | APP | 09-004 | 5221A |  | 09-012 | 09-052 |  |  |
| 15221018A |  | Proc SciFi Mods P-2 FY10 January Delivery | 101d | 2009-09-09 A | 2010-02-09 A | 15221018 FS-74d | 100% |  |  |  |  |  |  | PROCUREMENT>$50K 69 NO ESCALATION | 103,944 |  | 0 | 103944 | CHUDAKOV | 1 | 1 |  | D |  | P | EUGENE C |  |  |  | 11-006 | 11-026 | 12-021F | 12-054F |  |  |  |  |  |  | 0 | 103944 | 10394400 | 100 |  |  |  |  |  |  |  |  |  |  |  |  |  |  |  |  | 1 |  |  | APP |  | 5221A |  |  | 09-052 |  |  |
| 15221018B |  | Proc SciFi Mods P-2 FY10 February Delivery | 129d | 2009-09-09 A | 2010-03-22 A | 15221018A FS-94d | 100% |  |  |  |  |  |  | PROCUREMENT>$50K 69 NO ESCALATION | 103,944 |  | 0 | 103944 | CHUDAKOV | 1 | 1 |  | D |  | P | EUGENE C |  |  |  | 11-006 | 11-026 | 12-021F | 12-054F |  |  |  |  |  |  | 0 | 103944 | 10394400 | 100 |  |  |  |  |  |  |  |  |  |  |  |  |  |  |  |  | 1 |  |  | APP |  | 5221A |  |  | 09-052 |  |  |
| 15221018C |  | Proc SciFi Mods P-2 FY10 March Delivery | 134d | 2009-09-09 A | 2010-03-29 A | 15221018B FS-113d | 100% |  |  |  |  |  |  | PROCUREMENT>$50K 69 NO ESCALATION | 103,944 |  | 0 | 103944 | CHUDAKOV | 1 | 1 |  | D |  | P | EUGENE C |  |  |  | 11-006 | 11-026 | 12-021F | 12-054F |  |  |  |  |  |  | 0 | 103944 | 10394400 | 100 |  |  |  |  |  |  |  |  |  |  |  |  |  |  |  |  | 1 |  |  | APP |  | 5221A |  |  | 09-052 |  |  |
| 15221018D |  | Proc SciFi Mods P-2 FY10 April Delivery | 154d | 2009-09-09 A | 2010-04-26 A | 15221018C FS-136d | 100% |  |  |  |  |  |  | PROCUREMENT>$50K 69 NO ESCALATION | 103,944 |  | 0 | 103944 | CHUDAKOV | 1 | 1 |  | D |  | P | EUGENE C |  |  |  | 11-006 | 11-026 | 12-021F | 12-054F |  |  |  |  |  |  | 0 | 103944 | 10394400 | 100 |  |  |  |  |  |  |  |  |  |  |  |  |  |  |  |  | 1 |  |  | APP |  | 5221A |  |  | 09-052 |  |  |
| 15221018F |  | Proc SciFi Mods P-2 FY10 May Delivery | 174d | 2009-09-09 A | 2010-05-24 A | 15221018D FS-158d | 100% |  |  |  |  |  |  | PROCUREMENT>$50K 69 NO ESCALATION | 103,944 |  | 0 | 103944 | CHUDAKOV | 1 | 1 |  | D |  | P | EUGENE C |  |  |  | 11-006 | 11-026 | 12-021F | 12-054F |  |  |  |  |  |  | 0 | 103944 | 10394400 | 100 |  |  |  |  |  |  |  |  |  |  |  |  |  |  |  |  | 1 |  |  | APP |  | 5221A |  |  | 09-052 |  |  |
| 15221018G |  | Proc SciFi Mods P-2 FY10 June Delivery | 198d | 2009-09-09 A | 2010-06-28 A | 15221018F FS-178d | 100% |  |  |  |  |  |  | PROCUREMENT>$50K 69 NO ESCALATION | 103,944 |  | 0 | 103944 | CHUDAKOV | 1 | 1 |  | D |  | P | EUGENE C |  |  |  | 11-006 | 11-026 | 12-021F | 12-054F |  |  |  |  |  |  | 0 | 103944 | 10394400 | 100 |  |  |  |  |  |  |  |  |  |  |  |  |  |  |  |  | 1 |  |  | APP |  | 5221A |  |  | 09-052 |  |  |
| 15221018H |  | Proc SciFi Mods P-2 FY10 July Delivery | 221d | 2009-09-09 A | 2010-07-30 A | 15221018G FS-200d | 100% |  |  |  |  |  |  | PROCUREMENT>$50K 69 NO ESCALATION | 103,944 |  | 0 | 103944 | CHUDAKOV | 1 | 1 |  | D |  | P | EUGENE C |  |  |  | 11-006 | 11-026 | 12-021F | 12-054F |  |  |  |  |  |  | 0 | 103944 | 10394400 | 100 |  |  |  |  |  |  |  |  |  |  |  |  |  |  |  |  | 1 |  |  | APP |  | 5221A |  |  | 09-052 |  |  |
| 15221018J |  | Proc SciFi Mods P-2 FY10 August Delivery | 241d | 2009-09-09 A | 2010-08-27 A | 15221018H FS-221d | 100% |  |  |  |  |  |  | PROCUREMENT>$50K 69 NO ESCALATION | 103,944 |  | 0 | 103944 | CHUDAKOV | 1 | 1 |  | D |  | P | EUGENE C |  |  |  | 11-006 | 11-026 | 12-021F | 12-054F |  |  |  |  |  |  | 0 | 103944 | 10394400 | 100 |  |  |  |  |  |  |  |  |  |  |  |  |  |  |  |  | 1 |  |  | APP |  | 5221A |  |  | 09-052 |  |  |
| 15221018K |  | Proc SciFi Mods P-2 FY10 September Delivery | 264d | 2009-09-09 A | 2010-09-30 A | 15221018J FS-243d | 100% |  |  |  |  |  |  | PROCUREMENT>$50K 69 NO ESCALATION | 103,944 |  | 0 | 103944 | CHUDAKOV | 1 | 1 |  | D |  | P | EUGENE C |  |  |  | 11-006 | 11-026 | 12-021F | 12-054F |  |  |  |  |  |  | 0 | 103944 | 10394400 | 100 |  |  |  |  |  |  |  |  |  |  |  |  |  |  |  |  | 1 |  |  | APP |  | 5221A |  |  | 09-052 |  |  |
| 15221012A |  | Proc SciFi Mods P-1 Correction to Match award per CR09-052 | 1d | 2009-09-14 A | 2009-09-14 A | 9-090M FS+238d | 100% |  |  |  |  |  |  | PROCUREMENT>$50K 69 | -1,448.4 |  |  |  | CHUDAKOV | 1 | 1 |  | D | 07-024 | H | EUGENE C |  |  |  |  |  |  |  |  |  |  |  |  |  |  |  |  | 100 |  |  | 08-016 |  |  |  |  |  |  |  |  |  |  |  |  |  | 1 | CVL | 5 | APP | 09-004 | 5221A |  | 09-012 | 09-052 |  |  |
| 15221005 |  | FY10 Engineering Support for Procurements (BarCal) | 248d | 2009-10-01 A | 2010-09-30 A | 9-100M | 100% |  |  |  |  |  |  | MECH ENG [40 h]; MECH DES [20 h] | 3,538.8 | 3,538.8 | 0 | 3538.8 | CHUDAKOV | 1 | 1 |  | D | 07-024 | E | EUGENE C |  | 09-027 | 09-027 | 11-006 | 11-026 | 12-021F | 12-054F |  |  |  | 100 | 100 |  |  |  |  |  |  |  |  |  |  |  |  |  |  |  |  |  |  |  |  |  |  |  |  |  |  |  |  |  |  |  |  |
| 15221010E |  | FY10 Travel (BarCal) | 248d | 2009-10-01 A | 2010-09-30 A | 15221009E | 100% |  |  |  |  |  |  | TRAVEL | 7,617.88 |  | 0 | 7617.877922 | CHUDAKOV | 1 | 1 |  | D | 07-024 | E | EUGENE C |  |  |  | 11-006 | 11-026 |  |  |  |  |  | 100 | 100 |  |  |  |  |  |  |  |  |  |  |  |  |  |  |  |  |  |  |  |  |  |  |  |  |  |  |  |  |  |  |  |  |
| 15221070 |  | Proc Lead Sheets 25-30 (BarCal) | 6d | 2009-10-13 A | 2009-10-20 A | 15221060 | 100% |  |  |  |  |  |  | PROCUREMENT<$50K 60 | 24,490.81 |  | 0 | 24490.80503 | CHUDAKOV | 1 | 1 |  | D |  | D | EUGENE C |  |  |  | 11-006 | 11-026 | 12-021F | 12-054F |  |  |  |  |  |  | 0 | 24490.80503 | 2449080.503 | 100 |  |  |  |  |  |  |  |  |  |  |  |  |  |  |  |  |  |  |  |  |  |  |  |  |  |  |  |
| 15221080 |  | Proc Lead Sheets 7-12 (BarCal) | 24d | 2009-10-26 A | 2009-11-30 A | 15221070 | 100% |  |  |  |  |  |  | PROCUREMENT<$50K 60 | 24,490.81 |  | 0 | 24490.80503 | CHUDAKOV | 1 | 1 |  | D |  | D | EUGENE C |  |  |  | 11-006 | 11-026 | 12-021F | 12-054F |  |  |  |  |  |  | 0 | 24490.80503 | 2449080.503 | 100 |  |  |  |  |  |  |  |  |  |  |  |  |  |  |  |  |  |  |  |  |  |  |  |  |  |  |  |
| 15221090 |  | Proc Lead Sheets 31-36 (BarCal) | 14d | 2009-11-09 A | 2009-11-30 A | 15221080 | 100% |  |  |  |  |  |  | PROCUREMENT<$50K 60 NO ESCALATION FY10 | 24,490.81 |  | 0 | 24490.80503 | CHUDAKOV | 1 | 1 |  | D |  | D | EUGENE C |  |  |  | 11-006 | 11-026 | 12-021F | 12-054F |  |  |  |  |  |  | 0 | 24490.80503 | 2449080.503 | 100 |  |  | 08-016 |  |  |  |  |  |  |  |  |  |  |  |  |  |  |  |  |  |  |  |  | 09-012 |  |  |  |
| 15221045 |  | Proc 2nd Swaging machine (BarCal) | 29d | 2010-01-11 A | 2010-02-22 A | 9-090M FS+120d | 100% |  |  |  |  |  |  | PROCUREMENT<$50K 60 | 26,620.44 |  | 0 | 26620.44025 | CHUDAKOV | 1 | 1 |  | D |  | D | EUGENE C | 09-014 |  |  | 11-006 | 11-026 | 12-021F | 12-054F |  |  |  |  |  |  | 0 | 26620.44025 | 2662044.025 | 100 |  |  |  |  |  |  |  |  |  |  |  |  |  |  |  |  |  |  |  | APP |  | 5221B | 09-043 |  |  |  |  |
| 15221100 |  | Proc Lead Sheets 13-18 (BarCal) | 16d | 2010-02-01 A | 2010-02-23 A | 9-100M, 15221090 | 100% |  |  |  |  |  |  | PROCUREMENT<$50K 60 | 25,272.07 |  | 0 | 25272.066839 | CHUDAKOV | 1 | 1 |  | D |  | D | EUGENE C |  |  |  | 11-006 | 11-026 | 12-021F | 12-054F |  |  |  |  |  |  | 0 | 25272.066839 | 2527206.6839 | 100 |  |  |  |  |  |  |  |  |  |  |  |  |  |  |  |  |  |  |  |  |  |  |  |  |  |  |  |
| 15221115 |  | Proc Lead Sheets 37-42 (BarCal) | 10d | 2010-02-08 A | 2010-02-22 A | 15221100 | 100% |  |  |  |  |  |  | PROCUREMENT<$50K 60 | 25,272.07 |  | 0 | 25272.066839 | CHUDAKOV | 1 | 1 |  | D |  | D | EUGENE C |  |  |  | 11-006 | 11-026 | 12-021F | 12-054F |  |  |  |  |  |  | 0 | 25272.066839 | 2527206.6839 | 100 |  |  |  |  |  |  |  |  |  |  |  |  |  |  |  |  |  |  |  |  |  |  |  |  |  |  |  |
| 15221130 |  | Proc Lead Sheets 19-24 (BarCal) | 35d | 2010-02-08 A | 2010-03-29 A | 15221115 | 100% |  |  |  |  |  |  | PROCUREMENT<$50K 60 | 25,272.07 |  | 0 | 25272.066839 | CHUDAKOV | 1 | 1 |  | D |  | D | EUGENE C |  |  |  | 11-006 | 11-026 | 12-021F | 12-054F |  |  |  |  |  |  | 0 | 25272.066839 | 2527206.6839 | 100 |  |  |  |  |  |  |  |  |  |  |  |  |  |  |  |  |  |  |  |  |  |  |  |  |  |  |  |
| 15221145 |  | Proc Lead Sheets 43-48 (BarCal) | 35d | 2010-02-08 A | 2010-03-29 A | 15221130 | 100% |  |  |  |  |  |  | PROCUREMENT<$50K 60 NO ESCALATION FY11 | 25,272.07 |  | 0 | 25272.066839 | CHUDAKOV | 1 | 1 |  | D |  | D | EUGENE C |  |  |  | 11-006 | 11-026 | 12-021F | 12-054F |  |  |  |  |  |  | 0 | 25272.066839 | 2527206.6839 | 100 |  |  | 08-016 |  |  |  |  |  |  |  |  |  |  |  |  |  |  |  |  |  |  |  | 09-043 | 09-012 |  |  |  |
| 15221165 |  | Proc PMT's & Dividers (BarCal) | 15d | 2010-03-01 A | 2010-03-19 A | 9-100M FS+60d | 100% |  |  |  |  |  |  |  |  |  |  | 0 | CHUDAKOV | 1 | 1 |  | D |  | D | EUGENE C |  |  |  | 11-006 | 11-026 | 12-021F | 12-054F |  |  |  |  |  |  |  |  |  |  |  |  |  |  |  |  |  |  |  |  |  |  |  |  |  |  |  |  |  |  |  |  | 09-043 |  |  |  | 10-024 |

Notes:
- 25213015: Steps: Structural analysis (done); Check Drawings; Release drawing package; Issue procurment
- 25213015a: Steps: Structural analysis (done); Check Drawings; Release drawing package; Issue procurment
- 25213025: Steps: __Layup_carbon_fiber_tube; set up tool; glue rohacel sections; glue rohacel to support ring; QA
- 15221050: Steps: Procure Air Cylinders (done); Machine Components (done); Assemble Frame (done); Install pneumatics (done); Test System (done)

| ID | Activity | Type | Duration | Start | Finish | Predecessors | Complete | Planned start | Planned finish | Resources | Cost | Actual cost | Calculated Remaining Total Cost | MONTHLY EV COST | RESP - Responsibility | STRT%COMP for CM EVM | FNSH%COMP for CM EVM | 12 GeV 2nd level Critical Path | HALL D Related Milestones | CR 07-024 | EVMS Reporting Codes | CAM RESPONSIBLE | Activities with Steps | CR 09-014 | CR 09-027 | CR 09-027 Repair | CR 10-002 | CR 11-006 | CR 11-026 | CR 12-021 | CR 12-054 | LOE % Pre Calc | LOE % | LOE Divider | LOE Multiplier | Remaining Material Cost Based on % Compl | Claimed Material Cost Based on % Complet | Initial Claimed Material Calc | Claimed Material Divider | 12 GeV 1st level Critical Path | CIVIL CRITICAL MILESTONES | Advance Purchase Plan > 500K | 12 GEV MAJOR PROCUREMENT CATAGORY | CR 11-019 | Inter Project Link (IPL) | CR 10-024 | CR 11-001 | CR 09-043 | CR 10-042 | CR 11-011 | CR 11-040 | CR 11-049 | CR 08-016 | CR 12-055 | CR 12-001 | CR 11-048 | Profile change | CR 09-052 | CR 12-017 | Phil Dev | MARCH!!! | CR 12-053 | CR 11-054 |
| --- | --- | --- | --- | --- | --- | --- | --- | --- | --- | --- | --- | --- | --- | --- | --- | --- | --- | --- | --- | --- | --- | --- | --- | --- | --- | --- | --- | --- | --- | --- | --- | --- | --- | --- | --- | --- | --- | --- | --- | --- | --- | --- | --- | --- | --- | --- | --- | --- | --- | --- | --- | --- | --- | --- | --- | --- | --- | --- | --- | --- | --- | --- | --- |
| 15221003 | Prep Procur Packages for Si PM's/ Light guides 2010 (BarCal) |  | 274d | 2010-03-25 A | 2011-04-29 A | 9-100M FS+120d | 100% |  |  | MECH DES [560 h]; MECH ENG [400 h] | 52,521.63 | 52,521.63 | 0 | 51674.4 | CHUDAKOV | 1 | 1 | 2 | D | 07-024 | S | EUGENE C | ST | 09-014 | 09-027 | 09-027 | 10-002 | 11-006 | 11-026 | 12-021F | 12-054F |  |  |  |  |  |  |  |  |  |  |  |  |  |  |  |  |  |  |  |  |  |  |  |  |  |  |  |  |  |  |  |  |
| 15221008 | Prep Procur Packages Shipping Fixture/Support Frame 2011 (BarCal) |  | 72d | 2010-06-21 A | 2010-09-30 A | 9-110M | 100% |  |  | MECH DES [200 h] | 9,048 | 9,048 | 0 | 9336 | CHUDAKOV | 1 | 1 | 2 | D | 07-024 | H | EUGENE C |  | 09-014 | 09-027 | 09-027 |  | 11-006 | 11-026 | 12-021F |  |  |  |  |  |  |  |  |  |  |  |  |  |  |  |  |  |  |  |  |  |  |  |  |  |  |  |  |  |  |  |  |  |
| 15221004 | Prep Light Guide Procurement Package (BarCal) |  | 18d | 2010-10-01 A | 2010-10-26 A | 15221003 | 100% |  |  | MECH DES [160 h]; MECH ENG [80 h] | 12,904.8 | 12,904.8 | 0 | 12506.4 | CHUDAKOV | 1 | 1 | 2 | D | 07-024 | H | EUGENE C |  | 09-014 | 09-027 | 09-027 | 10-002 | 11-006 | 11-026 | 12-021F | 12-054F |  |  |  |  |  |  |  |  |  |  |  |  |  |  |  |  |  |  |  |  |  |  |  |  |  |  |  |  |  |  |  |  |
| 15221011E | FY11 Travel (BarCal) |  | 248d | 2010-10-01 A | 2011-09-30 A | 15221010E | 100% |  |  | TRAVEL | 7,860.89 |  | 0 | 7860.89 | CHUDAKOV | 1 | 1 |  | D | 07-024 | E | EUGENE C |  |  |  |  |  | 11-006 | 11-026 |  |  | 8.46774193 | 91.53225806 | 100 | 100 |  |  |  |  |  |  |  |  |  |  |  |  |  |  |  |  |  |  |  |  |  |  |  |  |  |  |  |  |
| 15221018N | Proc SciFi Mods P-3 FY11 December Delivery |  | 60d | 2010-10-01 A | 2011-01-04 A | 195221001 FS-41d | 100% |  |  | PROCUREMENT<$50K 60 NO ESCALATION; PROCUREMENT>$50K 69 NO ESCALATION | 104,886.31 |  | 0 | 104886.31 | CHUDAKOV | 1 | 1 |  | D |  | P | EUGENE C |  |  |  |  |  | 11-006 | 11-026 | 12-021F | 12-054F |  |  |  |  | 0 | 104886.31 | 10488631 | 100 | 1 | CVL | APP | 5221A | 11-019 |  |  |  |  |  |  |  |  |  |  |  |  |  |  |  |  |  |  |  |
| 15221018P | Proc SciFi Mods P-3 FY11 January Delivery |  | 78d | 2010-10-01 A | 2011-01-31 A | 15221018N FS-58d | 100% |  |  | PROCUREMENT<$50K 60 NO ESCALATION; PROCUREMENT>$50K 69 NO ESCALATION | 104,886.31 |  | 0 | 104886.31 | CHUDAKOV | 1 | 1 |  | D |  | P | EUGENE C |  |  |  |  |  | 11-006 | 11-026 | 12-021F | 12-054F |  |  |  |  | 0 | 104886.31 | 10488631 | 100 | 1 | CVL | APP | 5221A | 11-019 |  |  |  |  |  |  |  |  |  |  |  |  |  |  |  |  |  |  |  |
| 15221018Q | Proc SciFi Mods P-3 FY11 February Delivery |  | 96d | 2010-10-01 A | 2011-02-25 A | 15221018P FS-78d | 100% |  |  | PROCUREMENT>$50K 69 NO ESCALATION; PROCUREMENT<$50K 60 NO ESCALATION | 104,886.31 |  | 0 | 104886.31 | CHUDAKOV | 1 | 1 |  | D |  | P | EUGENE C |  |  |  |  |  | 11-006 | 11-026 | 12-021F | 12-054F |  |  |  |  | 0 | 104886.31 | 10488631 | 100 | 1 |  | APP | 5221A | 11-019 |  |  |  |  |  |  |  |  |  |  |  |  |  |  |  |  |  |  |  |
| 15221018R | Proc SciFi Mods P-3 FY11 March Delivery |  | 116d | 2010-10-01 A | 2011-03-25 A | 15221018Q FS-97d | 100% |  |  | PROCUREMENT<$50K 60 NO ESCALATION; PROCUREMENT>$50K 69 NO ESCALATION | 104,886.31 |  | 0 | 104886.31 | CHUDAKOV | 1 | 1 |  | D |  | P | EUGENE C |  |  |  |  |  | 11-006 | 11-026 | 12-021F | 12-054F |  |  |  |  | 0 | 104886.31 | 10488631 | 100 | 1 |  | APP | 5221A | 11-019 |  |  |  |  |  |  |  |  |  |  |  |  |  |  |  |  |  |  |  |
| 15221018S | Proc SciFi Mods P-3 FY11 April Delivery |  | 161d | 2010-10-01 A | 2011-05-27 A | 15221018R FS-120d | 100% |  |  | PROCUREMENT<$50K 60 NO ESCALATION; PROCUREMENT>$50K 69 NO ESCALATION | 104,886.31 |  | 0 | 104886.31 | CHUDAKOV | 1 | 1 |  | D |  | P | EUGENE C |  |  |  |  |  | 11-006 | 11-026 | 12-021F | 12-054F |  |  |  |  | 0 | 104886.31 | 10488631 | 100 | 1 |  | APP | 5221A | 11-019 |  |  |  |  |  |  |  |  |  |  |  |  |  |  |  |  |  |  |  |
| 15221018T | Proc SciFi Mods P-3 FY11 May Delivery |  | 176d | 2010-10-01 A | 2011-06-20 A | 15221018S FS-141d | 100% |  |  | PROCUREMENT<$50K 60 NO ESCALATION; PROCUREMENT>$50K 69 NO ESCALATION | 104,886.31 |  | 0 | 104886.31 | CHUDAKOV | 1 | 1 |  | D |  | P | EUGENE C |  |  |  |  |  | 11-006 | 11-026 | 12-021F | 12-054F |  |  |  |  | 0 | 104886.31 | 10488631 | 100 | 1 |  | APP | 5221A | 11-019 |  |  |  |  |  |  |  |  |  |  |  |  |  |  |  |  |  |  |  |
| 15221018U | Proc SciFi Mods P-3 FY11 June Delivery |  | 201d | 2010-10-01 A | 2011-07-26 A | 15221018T FS-162d | 100% |  |  | PROCUREMENT>$50K 69 NO ESCALATION; PROCUREMENT<$50K 60 NO ESCALATION | 101,771.83 |  | 0 | 101771.83 | CHUDAKOV | 1 | 1 |  | D |  | P | EUGENE C |  |  |  |  |  | 11-006 | 11-026 | 12-021F | 12-054F |  |  |  |  | 0 | 101771.83 | 10177183 | 100 | 1 |  | APP | 5221A | 11-019 |  |  |  |  |  |  |  |  |  |  |  |  |  |  |  |  |  |  |  |
| 15221018V | Proc SciFi Mods P-3 FY11 July Delivery |  | 201d | 2010-10-01 A | 2011-07-26 A | 15221018U FS-184d | 100% |  |  | PROCUREMENT<$50K 60 NO ESCALATION; PROCUREMENT>$50K 69 NO ESCALATION | 101,771.83 |  | 0 | 101771.83 | CHUDAKOV | 1 | 1 |  | D |  | P | EUGENE C |  |  |  |  |  | 11-006 | 11-026 | 12-021F | 12-054F |  |  |  |  | 0 | 101771.83 | 10177183 | 100 | 1 |  | APP | 5221A | 11-019 |  |  |  |  |  |  |  |  |  |  |  |  |  |  |  |  |  |  |  |
| 15221018W | Proc SciFi Mods P-3 FY11 August Delivery |  | 215d | 2010-10-01 A | 2011-08-15 A | 15221018V FS-204d | 100% |  |  | PROCUREMENT>$50K 69 NO ESCALATION; PROCUREMENT<$50K 60 NO ESCALATION | 101,771.83 |  | 0 | 101771.83 | CHUDAKOV | 1 | 1 |  | D |  | P | EUGENE C |  |  |  |  |  | 11-006 | 11-026 | 12-021F | 12-054F |  |  |  |  | 0 | 101771.83 | 10177183 | 100 | 1 |  | APP | 5221A | 11-019 |  |  |  |  |  |  |  |  |  |  |  |  |  |  |  |  |  |  |  |
| 15221018X | Proc SciFi Mods P-3 FY11 September Delivery |  | 258d | 2010-10-01 A | 2011-10-15 A | 15221018W FS-227d | 100% | 2010-10-01 | 2011-10-14 | PROCUREMENT>$50K 69 NO ESCALATION; PROCUREMENT<$50K 60 NO ESCALATION | 101,771.83 |  | 0 | 101771.83 | CHUDAKOV | 1 | 1 |  | D |  | P | EUGENE C |  |  |  |  |  | 11-006 | 11-026 | 12-021F | 12-054F |  |  |  |  | 0 | 101771.83 | 10177183 | 100 | 1 |  | APP | 5221A | 11-019 |  |  |  |  |  |  |  |  |  |  |  |  |  |  |  |  |  |  |  |
| 15221160b | Mechanical Drawings (Prototype) Including Temperature Stability (BarCal) FY10 |  | 116d | 2010-11-01 A | 2011-04-25 A | 9-100M FS+180d, 15221003 FS-120d | 100% |  |  | MECH ENG [294.67 h] | 20,022.83 | 20,022.83 | 0 | 19404.0195 | CHUDAKOV | 1 | 1 |  | D |  | H | EUGENE C |  |  |  |  |  | 11-006 | 11-026 | 12-021F | 12-054F |  |  |  |  |  |  |  |  |  |  | APP | 5221C |  | IPL | 10-024 | 11-001 |  |  |  |  |  |  |  |  |  |  |  |  |  |  |  |  |
| 15221157M | SiPM Contract Award (APP) | milestone | 0d | 2010-11-22 A | 2010-11-22 A | 9-110M FS+40d | 100% | 2010-11-30 | 2010-11-30 |  |  |  |  | 0 | CHUDAKOV | 1 | 1 |  | D |  | M | EUGENE C |  |  |  |  | 10-002 | 11-006 | 11-026 |  |  |  |  |  |  |  |  |  |  |  |  | APP | 5221C |  | IPL | 10-024 |  | 09-043 | 10-042 | 11-011 | 11-040 | 11-049 |  |  |  |  |  |  |  |  |  |  |  |
| 15221158 | Vend Fab SiPMs Peg Point #1 - First Article |  | 75d | 2010-12-01 A | 2011-03-25 A | 9-110M, 15221157M | 100% |  |  | PROCUREMENT<$50K 60 NO ESCALATION; PROCUREMENT>$50K 69 NO ESCALATION | 86,720 |  | 0 | 86720 | CHUDAKOV | 1 | 1 |  | D |  | D | EUGENE C |  |  |  |  | 10-002 | 11-006 | 11-026 |  |  |  |  |  |  | 0 | 86720 | 8672000 | 100 |  |  | APP | 5221C |  | IPL | 10-024 |  | 09-043 | 10-042 | 11-011 | 11-040 | 11-049 |  |  |  |  |  |  |  |  |  |  |  |
| 15221159 | Vend Fab SiPMs Peg Point #2 - Production Delivery #1 Qty 500 |  | 188d | 2010-12-01 A | 2011-09-02 A | 15221158M FS-125d | 100% |  |  | PROCUREMENT>$50K 69 NO ESCALATION | 262,500 |  | 0 | 262500 | CHUDAKOV | 1 | 1 |  | D |  | P | EUGENE C |  |  |  |  |  | 11-006 | 11-026 |  |  |  |  |  |  | 0 | 262500 | 26250000 | 100 |  |  | APP | 5221C |  | IPL |  |  |  |  | 11-011 | 11-040 | 11-049 |  |  |  |  |  |  |  |  |  |  |  |
| 15221159a | Vend Fab SiPMs Peg Point #3 - Production Delivery #2 Qty 500 |  | 205d | 2010-12-01 A | 2011-09-28 A | 15221159 FS-163d | 100% |  |  | PROCUREMENT>$50K 69 NO ESCALATION | 262,500 |  | 0 | 262500 | CHUDAKOV | 1 | 1 |  | D |  | P | EUGENE C |  |  |  |  |  | 11-006 | 11-026 |  |  |  |  |  |  | 0 | 262500 | 26250000 | 100 |  |  | APP | 5221C |  | IPL |  |  |  |  | 11-011 | 11-040 |  |  |  |  |  |  |  |  |  |  |  |  |
| 15221159b | Vend Fab SiPMs Peg Point #4 - Production Delivery #3 Qty 120 |  | 227d | 2010-12-01 A | 2011-10-28 A | 15221159a FS-186d | 100% |  |  | PROCUREMENT>$50K 69 NO ESCALATION | 63,000 |  | 0 | 63000 | CHUDAKOV | 1 | 1 |  | D |  | P | EUGENE C |  |  |  |  |  | 11-006 | 11-026 |  |  |  |  |  |  | 0 | 63000 | 6300000 | 100 |  |  | APP | 5221C |  | IPL |  |  |  |  | 11-011 | 11-040 |  |  |  |  |  |  |  |  |  |  |  |  |
| 15221160a | SiPM Elec Preamp/Sum, Temp stab, Mech cooling FY10 |  | 276d | 2011-01-03 A | 2012-02-13 A | 9-100M FS+180d, 15221003 FS-120d | 100% | 2011-01-04 | 2012-02-13 | ELEC DES [1065.33 h]; ELEC ENG [1065.33 h]; ELEC TECH [1065.33 h]; SUPPLIES & MATERIALS | 197,771.97 | 172,271.97 | 0 | 190796.6028 | CHUDAKOV | 1 | 1 |  | D |  | S | EUGENE C | ST |  |  |  |  | 11-006 | 11-026 | 12-021F | 12-054F |  |  |  |  |  |  |  |  |  |  | APP | 5221C |  | IPL | 10-024 | 11-001 |  |  |  |  |  |  |  |  |  |  |  |  |  |  |  |  |
| 15221173 | Proc Light Guides (BarCal) |  | 14d | 2011-01-04 A | 2011-01-24 A | 12322018M, 15221005 FS-130d, 9-100M FS+120d, 15221004 | 100% |  |  |  |  |  |  | 0 | CHUDAKOV | 1 | 1 |  | D |  | D | EUGENE C |  | 09-014 |  |  | 10-002 | 11-006 | 11-026 | 12-021F | 12-054F |  |  |  |  |  |  |  |  |  |  |  |  |  |  | 10-024 |  |  |  |  |  |  | 08-016 |  |  |  |  |  |  |  |  |  |  |
| 15221006 | FY11 Engineering Support for fabrication (BarCal) |  | 188d | 2011-01-05 A | 2011-09-30 A | 9-110M FS+60d | 100% |  |  | MECH ENG [120 h]; MECH DES [120 h] | 13,755.6 | 13,755.6 | 0 | 13755.6 | CHUDAKOV | 1 | 1 | 2 | D |  | E | EUGENE C |  |  |  |  |  | 11-006 | 11-026 | 12-021F | 12-054F | 11.17021276 | 88.82978723 | 100 | 100 |  |  |  |  |  |  |  |  |  |  |  |  |  |  |  |  |  |  |  |  |  |  |  |  |  |  |  |  |
| 15221147 | Drawings Light Guides (BarCal) |  | 140d | 2011-01-05 A | 2011-07-25 A | 9-110M FS+60d | 100% |  |  | MECH TECH [260 h]; MECH ENG [100 h]; SCIENTIST [160 h] | 28,942 | 28,942 | 0 | 28942 | CHUDAKOV | 1 | 1 |  | D |  | H | EUGENE C |  |  |  |  | 10-002 | 11-006 | 11-026 | 12-021F | 12-054F |  |  |  |  |  |  |  |  |  |  |  |  |  |  | 10-024 |  | 09-043 | 10-042 |  |  |  |  |  |  |  |  |  |  |  |  |  |  |
| 15221158b | SiPM First Article Test set up |  | 18d | 2011-02-01 A | 2011-02-28 A | 15221157M FS+39d | 100% | 2011-02-01 | 2011-02-25 | PROCUREMENT<$50K 60 NO ESCALATION | 10,000 |  | 0 | 10000 | CHUDAKOV | 1 | 1 |  | D |  | H | EUGENE C |  |  |  |  | 10-002 | 11-006 | 11-026 |  |  |  |  |  |  | 0 | 10000 | 1000000 | 100 |  |  | APP | 5221C |  | IPL | 10-024 |  | 09-043 | 10-042 | 11-011 | 11-040 | 11-049 |  |  |  |  |  |  |  |  |  |  |  |
| 15221158a | SiPM First Article Testing |  | 40d | 2011-03-01 A | 2011-04-25 A | 15221158, 15221157M FS+19d | 100% |  |  | SCIENTIST [1440 h] | 98,539.2 | 98,539.2 | 0 | 98539.2 | CHUDAKOV | 1 | 1 |  | D |  | U | EUGENE C |  |  |  |  | 10-002 | 11-006 | 11-026 |  |  |  |  |  |  |  |  |  |  |  |  | APP | 5221C |  | IPL | 10-024 |  | 09-043 | 10-042 | 11-011 | 11-040 | 11-049 |  |  |  |  |  |  |  |  |  |  |  |
| 15221158M | SiPM Notice To Begin Production | milestone | 0d | 2011-04-25 A | 2011-04-25 A | 15221158a, 15221158 FS+23d, 15221158b | 100% | 2011-05-02 | 2011-05-02 |  |  |  |  | 0 | CHUDAKOV | 1 | 1 |  | D |  | M | EUGENE C |  |  |  |  | 10-002 | 11-006 | 11-026 |  |  |  |  |  |  |  |  |  |  |  |  | APP | 5221C |  | IPL | 10-024 |  | 09-043 | 10-042 | 11-011 | 11-040 | 11-049 |  |  |  |  |  |  |  |  |  |  |  |
| 15221160ab | SiPM Elec Preamp/Sum, Temp stab, Mech cooling FY11 Part A |  | 343d | 2011-06-30 A | 2012-11-12 A | 15221160a FS-60d | 100% |  |  | ELEC DES [814.67 h]; ELEC ENG [814.67 h]; ELEC TECH [814.67 h]; MECH ENG [225.33 h]; PROCUREMENT<$50K 60; SUPPLIES & MATERIALS | 205,059.3 | 149,937.25 | 0 | 200861.8905 | CHUDAKOV | 1 | 1 |  | D |  | S | EUGENE C | ST |  |  |  |  | 11-006 | 11-026 | 12-021F | 12-054F |  |  |  |  | 0 | 35000 | 3500000 | 100 |  |  | APP | 5221C |  | IPL | 10-024 | 11-001 |  |  |  |  |  |  | 12-055 |  |  |  |  |  |  |  |  |  |
| 15221160ba | SiPM production testing FY11 |  | 242.4d | 2011-07-18 A | 2012-07-09 A | 15221159 FS-30d | 100% |  |  | MECH TECH [159.17 h]; ELEC TECH [159.17 h] | 14,000.88 | 14,000.89 | 0 | 13663.1528 | CHUDAKOV | 1 | 1 |  | D |  | S | EUGENE C | ST |  |  |  |  | 11-006 | 11-026 |  |  |  |  |  |  |  |  |  |  |  |  | APP | 5221C |  | IPL | 10-024 | 11-001 |  |  |  | 11-040 | 11-049 |  |  | 12-001 |  |  |  |  |  |  |  |  |
| 15221160baa | SiPM production testing FY12 |  | 243d | 2011-07-18 A | 2012-07-09 A | 15221160ba FS-180d | 100% |  |  | MECH TECH [662.01 h]; ELEC TECH [662.01 h] | 58,232.61 | 58,232.61 | 0 | 58634.2257 | CHUDAKOV | 1 | 1 |  | D |  | S | EUGENE C | ST |  |  |  |  | 11-006 | 11-026 |  |  |  |  |  |  |  |  |  |  |  |  | APP | 5221C |  | IPL | 10-024 | 11-001 |  |  |  | 11-040 | 11-049 |  |  | 12-001 |  |  |  |  |  |  |  |  |
| 15221160bb | SiPM production testing set up (materials) |  | 218d | 2011-07-25 A | 2012-06-11 A | 15221159 FS-30d | 100% |  |  | PROCUREMENT<$50K 60 NO ESCALATION FY12 | 53,999.37 |  | 0 | 53999.37 | CHUDAKOV | 1 | 1 |  | D |  | D | EUGENE C |  |  |  |  |  | 11-006 | 11-026 |  |  |  |  |  |  | 0 | 53999.37 | 5399937 | 100 |  |  | APP | 5221C |  | IPL | 10-024 | 11-001 |  |  |  | 11-040 | 11-049 |  |  |  |  |  |  |  |  |  |  |  |
| 15221007 | Prepare procurement packages for assembly tooling |  | 111d | 2011-08-01 A | 2012-01-16 A | 9-120M FS-25d | 100% | 2011-08-01 | 2012-01-13 | MECH ENG [280 h]; MECH TECH [200 h]; MECH DES [400 h] | 47,203.89 | 47,203.89 | 0 | 47789.6 | CHUDAKOV | 1 | 1 | 2 | D |  | H | EUGENE C |  |  |  |  |  | 11-006 | 11-026 | 12-021F |  |  |  |  |  |  |  |  |  |  |  |  |  |  |  |  |  |  |  |  |  |  |  |  |  |  |  |  |  |  |  |  |  |
| 15221020 | Completion of BCAL assembly work in factory, exchange rate coverage |  | 60d | 2011-08-01 A | 2011-10-24 A | 9-110M FS+204d | 100% |  |  | PROCUREMENT>$50K 69 NO ESCALATION; PROCUREMENT<$50K 60 NO ESCALATION | 311,000 |  | 0 | 311000 | CHUDAKOV | 1 | 1 |  | D |  | S | EUGENE C | ST |  |  |  |  |  |  | 12-021F | 12-054F |  |  |  |  | 0 | 311000 | 31100000 | 100 | 1 |  | APP | 5221A |  |  |  |  |  |  |  |  |  |  |  |  | 11-048 |  |  |  |  |  |  |  |
| 15221025 | Fabrication of matrix #49 |  | 85d | 2011-08-01 A | 2011-11-30 A | 9-110M FS+204d | 100% |  |  | PROCUREMENT>$50K 69 NO ESCALATION | 22,400 |  | 0 | 22400 | CHUDAKOV | 1 | 1 |  | D |  | P | EUGENE C |  |  |  |  |  |  |  | 12-021F | 12-054F |  |  |  |  | 0 | 22400 | 2240000 | 100 | 1 |  | APP | 5221A |  |  |  |  |  |  |  |  |  |  |  |  | 11-048 |  |  |  |  |  |  |  |
| 15221030 | Machining and shipping of matrix #49 |  | 98d | 2011-08-01 A | 2011-12-19 A | 15221025 FS-207d | 100% |  |  | PROCUREMENT>$50K 69 NO ESCALATION | 4,600 |  | 0 | 4600 | CHUDAKOV | 1 | 1 |  | D |  | P | EUGENE C |  |  |  |  |  |  |  | 12-021F | 12-054F |  |  |  |  | 0 | 4600 | 460000 | 100 | 1 |  | APP | 5221A |  |  |  |  |  |  |  |  |  |  |  |  | 11-048 |  |  |  |  |  |  |  |
| 15221155b | Light Tight Boxes (BarCal) |  | 370d | 2011-08-01 A | 2012-12-17 A | 15221003, 9-120M FS-22d | 100% | 2011-08-01 | 2013-01-30 | SUPPLIES & MATERIALS | 21,296.35 |  | 0 | 21296.35 | CHUDAKOV | 1 | 1 |  | D |  | D | EUGENE C |  |  |  |  |  | 11-006 | 11-026 | 12-021F |  |  |  |  |  |  |  |  |  |  |  |  |  |  |  | 10-024 |  |  | 10-042 |  |  |  |  |  |  |  |  |  |  |  |  |  |  |
| 15221180 | Proc Supprt Struct and assy tooling (BarCal) Part A |  | 302d | 2011-08-01 A | 2012-10-15 A | 9-120M FS-20d, 15221007 FS-100d, 15221008 | 100% |  |  | PROCUREMENT>$50K 69; PROCUREMENT<$50K 60 | 92,190 |  | 0 | 92190 | CHUDAKOV | 1 | 1 |  | D |  | D | EUGENE C |  |  |  |  |  | 11-006 | 11-026 | 12-021F |  |  |  |  |  | 0 | 92190 | 9219000 | 100 |  |  |  |  |  |  |  |  | 09-043 | 10-042 |  |  |  |  | 12-055 |  |  | C |  |  |  |  |  |  |
| 15221012E | FY12 Travel (BarCal) |  | 247d | 2011-10-03 A | 2012-09-28 A | 15221011E | 100% |  |  | TRAVEL | 6,590.64 |  | 0 | 6590.64 | CHUDAKOV | 1 | 1 |  | D | 07-024 | E | EUGENE C |  |  |  |  |  | 11-006 | 11-026 |  |  | 7.69230769 | 92.3076923 | 100 | 100 |  |  |  |  |  |  |  |  |  |  |  |  | 09-043 |  |  |  |  |  |  |  |  |  | 09-052 |  |  |  |  |  |
| 15221150 | Proc Light Guides First Article (BarCal) |  | 44d | 2011-10-17 A | 2011-12-19 A | 15221147 FS+64d, 15221003 | 100% |  |  | PROCUREMENT>$50K 69 | 10,000 |  | 0 | 10000 | CHUDAKOV | 1 | 1 |  | D |  | D | EUGENE C |  |  |  |  | 10-002 | 11-006 | 11-026 | 12-021F | 12-054F |  |  |  |  | 0 | 10000 | 1000000 | 100 |  |  |  |  |  |  | 10-024 |  | 09-043 | 10-042 |  |  |  |  |  |  |  |  |  | 12-017 |  |  |  |  |
| 15221155 | Vend Fab Light Guides (WC) Peg Point # 1 - Materials |  | 49d | 2011-10-17 A | 2012-01-03 A | 9-110M FS+60d, 15221003, 15221150 FS-44d | 100% |  |  | PROCUREMENT<$50K 60 NO ESCALATION | 50,000 |  | 0 | 50000 | CHUDAKOV | 1 | 1 |  | D |  | D | EUGENE C |  |  |  |  | 10-002 | 11-006 | 11-026 | 12-021F | 12-054F |  |  |  |  | 0 | 50000 | 5000000 | 100 |  |  |  |  |  |  | 10-024 |  | 09-043 | 10-042 |  |  |  |  |  |  |  |  |  | 12-017 |  |  |  |  |
| 15221156 | Vend Fab Light Guides (WC) Peg Point # 2 - First Article Delivery |  | 75d | 2011-10-17 A | 2012-02-09 A | 15221155 FS-58d | 100% |  |  | PROCUREMENT>$50K 69 NO ESCALATION | 6,800 |  | 0 | 6800 | CHUDAKOV | 1 | 1 |  | D |  | D | EUGENE C |  |  |  |  |  |  |  | 12-021F | 12-054F |  |  |  |  | 0 | 6800 | 680000 | 100 |  |  |  |  |  |  |  |  |  |  |  |  |  |  |  |  |  |  |  | 12-017 |  |  |  |  |
| 15221156a | Vend Fab Light Guides (WC) Peg Point # 3 - 1st Production Delivery |  | 248d | 2011-10-17 A | 2012-10-15 A | 15221156 FS-58d | 100% |  |  | PROCUREMENT>$50K 69 NO ESCALATION | 33,320 |  | 0 | 33320 | CHUDAKOV | 1 | 1 |  | D |  | D | EUGENE C |  |  |  |  |  |  |  | 12-021F | 12-054F |  |  |  |  | 0 | 33320 | 3332000 | 100 |  |  |  |  |  |  |  |  |  |  |  |  |  |  |  |  |  |  |  | 12-017 | MP |  |  |  |
| 15221156b | Vend Fab Light Guides (WC) Peg Point # 4 -2nd Production Delivery |  | 268d | 2011-10-17 A | 2012-11-12 A | 15221156a FS-100d | 100% |  |  | PROCUREMENT>$50K 69 NO ESCALATION | 33,320 |  | 0 | 33320 | CHUDAKOV | 1 | 1 |  | D |  | D | EUGENE C |  |  |  |  |  |  |  | 12-021F | 12-054F |  |  |  |  | 0 | 33320 | 3332000 | 100 |  |  |  |  |  |  |  |  |  |  |  |  |  |  |  |  |  |  |  | 12-017 | MP |  |  |  |
| 15221156c | Vend Fab Light Guides (WC) Peg Point # 5 - 3rd Production Delivery |  | 268d | 2011-10-17 A | 2012-11-12 A | 15221156b FS-121d | 100% |  |  | PROCUREMENT>$50K 69 NO ESCALATION | 33,320 |  | 0 | 33320 | CHUDAKOV | 1 | 1 |  | D |  | D | EUGENE C |  |  |  |  |  |  |  | 12-021F | 12-054F |  |  |  |  | 0 | 33320 | 3332000 | 100 |  |  |  |  |  |  |  |  |  |  |  |  |  |  |  |  |  |  |  | 12-017 | MP |  |  |  |
| 15221156d | Vend Fab Light Guides (WC) Peg Point # 6 - 4th Production Delivery |  | 306d | 2011-10-17 A | 2012-12-17 A | 15221156c FS-143d | 100% | 2011-10-17 | 2013-01-15 | PROCUREMENT>$50K 69 NO ESCALATION | 33,320 |  | 0 | 33320 | CHUDAKOV | 1 | 1 |  | D |  | D | EUGENE C |  |  |  |  |  |  |  | 12-021F | 12-054F |  |  |  |  | 0 | 33320 | 3332000 | 100 |  |  |  |  |  |  |  |  |  |  |  |  |  |  |  |  |  |  |  | 12-017 | MP |  |  |  |
| 15221156f | Vend Fab Light Guides (WC) Peg Point # 7 - 5th Production Delivery |  | 306d | 2011-10-17 A | 2013-01-14 A | 15221156d FS-163d | 100% | 2011-10-17 | 2013-01-15 | PROCUREMENT>$50K 69 NO ESCALATION | 33,320 |  | 0 | 33320 | CHUDAKOV | 1 | 1 |  | D |  | D | EUGENE C |  |  |  |  |  |  |  | 12-021F | 12-054F |  |  |  |  | 0 | 33320 | 3332000 | 100 |  |  |  |  |  |  |  |  |  |  |  |  |  |  |  |  |  |  |  | 12-017 | MP | XX |  |  |
| 15221156g | Vend Fab Light Guides (WC) Peg Point # 8 - 6th Production Delivery |  | 328d | 2011-10-17 A | 2013-01-14 A | 15221156f FS-163d | 100% | 2011-10-17 | 2013-02-15 | PROCUREMENT>$50K 69 NO ESCALATION | 33,320 |  | 0 | 33320 | CHUDAKOV | 1 | 1 |  | D |  | D | EUGENE C |  |  |  |  |  |  |  | 12-021F | 12-054F |  |  |  |  | 0 | 33320 | 3332000 | 100 |  |  |  |  |  |  |  |  |  |  |  |  |  |  |  |  |  |  |  | 12-017 | MP | XX |  |  |
| 15221156h | Vend Fab Light Guides (WC) Peg Point # 9 - 7th Production Delivery |  | 328d | 2011-10-17 A | 2013-01-14 A | 15221156g FS-185d | 100% | 2011-10-17 | 2013-02-15 | PROCUREMENT>$50K 69 NO ESCALATION | 33,320 |  | 0 | 33320 | CHUDAKOV | 1 | 1 |  | D |  | D | EUGENE C |  |  |  |  |  |  |  | 12-021F | 12-054F |  |  |  |  | 0 | 33320 | 3332000 | 100 |  |  |  |  |  |  |  |  |  |  |  |  |  |  |  |  |  |  |  | 12-017 | MP | XX |  |  |
| 15221156j | Vend Fab Light Guides (WC) Peg Point # 10 - 8th Production Delivery |  | 347d | 2011-10-17 A | 2013-01-14 A | 15221156h FS-185d | 100% | 2011-10-17 | 2013-03-15 | PROCUREMENT>$50K 69 NO ESCALATION | 33,320 |  | 0 | 33320 | CHUDAKOV | 1 | 1 |  | D |  | D | EUGENE C |  |  |  |  |  |  |  | 12-021F | 12-054F |  |  |  |  | 0 | 33320 | 3332000 | 100 |  |  |  |  |  |  |  |  |  |  |  |  |  |  |  |  |  |  |  | 12-017 | MP |  |  |  |
| 15221156k | Vend Fab Light Guides (WC) Peg Point # 11 - 9th Production Delivery |  | 347d | 2011-10-17 A | 2013-02-11 A | 15221156j FS-208d | 100% | 2011-10-17 | 2013-03-15 | PROCUREMENT>$50K 69 NO ESCALATION | 33,320 |  | 0 | 33320 | CHUDAKOV | 1 | 1 |  | D |  | D | EUGENE C |  |  |  |  |  |  |  | 12-021F | 12-054F |  |  |  |  | 0 | 33320 | 3332000 | 100 |  |  |  |  |  |  |  |  |  |  |  |  |  |  |  |  |  |  |  | 12-017 | MP |  |  |  |
| 15221156n | Vend Fab Light Guides (WC) Peg Point # 12 - 10th Production Delivery |  | 358d | 2011-10-17 A | 2013-02-11 A | 15221156k FS-208d | 100% | 2011-10-17 | 2013-04-01 | PROCUREMENT>$50K 69 NO ESCALATION | 33,320 |  | 0 | 33320 | CHUDAKOV | 1 | 1 |  | D |  | D | EUGENE C |  |  |  |  |  |  |  | 12-021F | 12-054F |  |  |  |  | 0 | 33320 | 3332000 | 100 |  |  |  |  |  |  |  |  |  |  |  |  |  |  |  |  |  |  |  | 12-017 | MP |  |  |  |
| 15221055 | Fabricate BCAL Calibration System (BarCal) Labor FY11 |  | 283d | 2011-12-01 A | 2013-01-14 A | 9-110M FS+141d, 1152055, 9-120M FS+45d | 100% | 2011-12-01 | 2013-01-28 | ELEC TECH [208.82 h] | 9,295.34 | 9,288.3 | 0 | 8931.2314 | CHUDAKOV | 1 | 1 |  | D |  | D | EUGENE C |  |  |  |  |  | 11-006 | 11-026 | 12-021F | 12-054F |  |  |  |  |  |  |  |  |  |  |  |  |  |  |  |  | 09-043 | 10-042 |  |  |  |  |  | 12-001 |  |  |  |  |  | XX |  |  |
| 15221055a | Fabricate BCAL Calibration System (BarCal) Labor FY12 |  | 283d | 2011-12-01 A | 2013-02-04 A | 15221055 FS-300d | 100% | 2011-12-01 | 2013-01-28 | ELEC TECH [275.18 h] | 12,249.26 | 12,254.17 | 0 | 12143.6934 | CHUDAKOV | 1 | 1 |  | D |  | D | EUGENE C |  |  |  |  |  | 11-006 | 11-026 | 12-021F | 12-054F |  |  |  |  |  |  |  |  |  |  |  |  |  |  |  |  | 09-043 | 10-042 |  |  |  |  |  | 12-001 |  |  |  |  |  | XX |  |  |
| 15221055b | Fabricate BCAL Calibration System (BarCal) Procurement |  | 283d | 2011-12-01 A | 2013-01-14 A | 1152055, 9-120M FS+45d | 100% | 2011-12-01 | 2013-01-28 | PROCUREMENT<$50K 60 NO ESCALATION FY12 | 30,957 |  | 0 | 30957 | CHUDAKOV | 1 | 1 |  | D |  | D | EUGENE C |  |  |  |  |  | 11-006 | 11-026 | 12-021F | 12-054F |  |  |  |  | 0 | 30957 | 3095700 | 100 |  |  |  |  |  |  |  |  | 09-043 | 10-042 |  |  |  |  |  | 12-001 |  |  |  |  |  | XX |  |  |
| 15221009 | FY12 Engineering Support for Fabrication (BarCal) |  | 126d | 2012-02-23 A | 2012-08-20 A | 15221006, 9-120M FS+93d | 100% |  |  | MECH ENG [120 h]; MECH DES [80 h] | 12,268 | 12,268 | 0 | 12268 | CHUDAKOV | 1 | 1 |  | D | 07-024 | E | EUGENE C |  |  | 09-027 | 09-027 |  | 11-006 | 11-026 | 12-021F | 12-054F | 11.11111111 | 88.88888888 | 100 | 100 |  |  |  |  |  |  |  |  |  |  |  |  | 09-043 |  |  |  |  |  |  |  |  |  |  |  |  |  |  |  |
| 15221160aba | SiPM Elec Preamp/Sum, Temp stab, Mech cooling FY11 Part B |  | 69d | 2012-10-01 A | 2013-01-14 A | 15221160a FS-60d | 100% | 2012-10-01 | 2013-01-15 | PROCUREMENT<$50K 60; PROCUREMENT>$50K 69 | 65,000 |  | 0 | 65000 | CHUDAKOV | 1 | 1 |  | D |  | D | EUGENE C |  |  |  |  |  | 11-006 | 11-026 | 12-021F | 12-054F |  |  |  |  | 0 | 65000 | 6500000 | 100 |  |  | APP | 5221C |  | IPL | 10-024 | 11-001 |  |  |  |  |  |  | 12-055 |  |  |  |  |  |  | XX |  |  |
| 15221161a | SiPM cool light guide grating |  | 44d | 2012-10-14 A | 2012-12-16 A | 15221160ab FS-60d, 9-130M, 15221160aba FS-60d | 100% | 2012-10-15 | 2012-12-17 | PROCUREMENT<$50K 60 | 10,319 |  | 0 | 10319 | CHUDAKOV | 1 | 1 |  | D |  | D | EUGENE C |  |  |  |  |  | 11-006 | 11-026 | 12-021 | 12-054 |  |  |  |  | 0 | 10319 | 1031900 | 100 |  |  | APP | 5221C |  | IPL | 10-024 | 11-001 |  |  |  |  |  |  |  |  |  |  |  |  |  |  |  |  |
| 15221161b | SiPM cool SiPM mount |  | 11d | 2012-11-03 A | 2012-11-19 A | 15221160aba FS-60d, 9-130M FS+24d, 15221160ab FS-60d | 100% | 2012-11-05 | 2012-11-19 | PROCUREMENT<$50K 60 | 10,319 |  | 0 | 10319 | CHUDAKOV | 1 | 1 |  | D |  | D | EUGENE C |  |  |  |  |  | 11-006 | 11-026 | 12-021 | 12-054 |  |  |  |  | 0 | 10319 | 1031900 | 100 |  |  | APP | 5221C |  | IPL | 10-024 | 11-001 |  |  |  |  |  |  |  |  |  |  |  |  |  |  |  |  |
| 15221161 | SiPM cool Procurement labor FY12 (FY13 @ 15221161s) |  | 34d | 2012-11-05 A | 2013-01-14 A | 15221160ab FS-80d, 9-130M, 15221160aba FS-80d, 9-120M FS+144d | 100% | 2012-11-05 | 2012-12-31 | MECH TECH [92.39 h]; ELEC TECH [369.55 h] | 21,066.32 | 21,066.32 | 0 | 20414.0531 | CHUDAKOV | 1 | 1 |  | D |  | H | EUGENE C |  |  |  |  |  | 11-006 | 11-026 | 12-021F | 12-054F |  |  |  |  |  |  |  |  |  |  | APP | 5221C |  | IPL | 10-024 | 11-001 |  |  |  |  |  |  |  |  |  |  |  |  |  | XX | 12-053 |  |
| 15221161c | SiPM cool Cooling plate |  | 29d | 2012-11-05 A | 2013-01-14 A | 15221160ab FS-60d, 15221160aba FS-60d, 9-130M FS+31d | 100% | 2012-11-05 | 2012-12-17 | PROCUREMENT<$50K 60; PROCUREMENT>$50K 69 | 51,595 |  | 0 | 51595 | CHUDAKOV | 1 | 1 |  | D |  | D | EUGENE C |  |  |  |  |  | 11-006 | 11-026 | 12-021 | 12-054 |  |  |  |  | 0 | 51595 | 5159500 | 100 |  |  | APP | 5221C |  | IPL | 10-024 | 11-001 |  |  |  |  |  |  |  |  |  |  |  |  |  | XX |  |  |
| 15221161f | SiPM cool Electronic heat removal |  | 29d | 2012-11-05 A | 2012-12-17 A | 9-130M FS+24d, 15221160ab FS-60d, 15221160aba FS-60d | 100% |  |  | PROCUREMENT<$50K 60 | 10,319 |  | 0 | 10319 | CHUDAKOV | 1 | 1 |  | D |  | D | EUGENE C |  |  |  |  |  | 11-006 | 11-026 | 12-021 | 12-054 |  |  |  |  | 0 | 10319 | 1031900 | 100 |  |  | APP | 5221C |  | IPL | 10-024 | 11-001 |  |  |  |  |  |  |  |  |  |  |  |  |  |  |  |  |
| 15221161h | SiPM cool light covers |  | 29d | 2012-11-05 A | 2012-12-16 A | 9-130M FS+24d, 15221160aba FS-60d, 15221160ab FS-60d | 100% | 2012-11-05 | 2012-12-17 | PROCUREMENT<$50K 60 | 10,319 |  | 0 | 10319 | CHUDAKOV | 1 | 1 |  | D |  | D | EUGENE C |  |  |  |  |  | 11-006 | 11-026 | 12-021 | 12-054 |  |  |  |  | 0 | 10319 | 1031900 | 100 |  |  | APP | 5221C |  | IPL | 10-024 | 11-001 |  |  |  |  |  |  |  |  |  |  |  |  |  |  |  |  |
| 15221161j | SiPM cool cable supports/layout |  | 29d | 2012-11-05 A | 2012-12-16 A | 9-130M FS+24d, 15221160ab FS-60d, 15221160aba FS-60d | 100% | 2012-11-05 | 2012-12-17 | PROCUREMENT<$50K 60 | 9,390.29 |  | 0 | 9390.29 | CHUDAKOV | 1 | 1 |  | D |  | D | EUGENE C |  |  |  |  |  | 11-006 | 11-026 | 12-021 | 12-054 |  |  |  |  | 0 | 9390.29 | 939029 | 100 |  |  | APP | 5221C |  | IPL | 10-024 | 11-001 |  |  |  |  |  |  |  |  |  |  |  |  |  |  |  |  |
| 15221161k | SiPM cool cooling tubes support/layout |  | 29d | 2012-11-05 A | 2013-02-11 A | 15221160ab FS-60d, 9-130M FS+24d, 15221160aba FS-60d | 100% | 2012-11-05 | 2012-12-17 | PROCUREMENT<$50K 60 | 10,319 |  | 0 | 10319 | CHUDAKOV | 1 | 1 |  | D |  | D | EUGENE C |  |  |  |  |  | 11-006 | 11-026 | 12-021 | 12-054 |  |  |  |  | 0 | 10319 | 1031900 | 100 |  |  | APP | 5221C |  | IPL | 10-024 | 11-001 |  |  |  |  |  |  |  |  |  |  |  |  |  | XX |  |  |
| 15221161n | SiPM cool mechanical support |  | 29d | 2012-11-05 A | 2012-12-16 A | 15221160aba FS-60d, 15221160ab FS-60d, 9-130M FS+24d | 100% | 2012-11-05 | 2012-12-17 | PROCUREMENT<$50K 60 | 12,382.8 |  | 0 | 12382.8 | CHUDAKOV | 1 | 1 |  | D |  | D | EUGENE C |  |  |  |  |  | 11-006 | 11-026 | 12-021 | 12-054 |  |  |  |  | 0 | 12382.8 | 1238280 | 100 |  |  | APP | 5221C |  | IPL | 10-024 | 11-001 |  |  |  |  |  |  |  |  |  |  |  |  |  |  |  |  |
| 15221161s | SiPM cool Procurement labor FY13 (FY12 @ 15221161) |  | 34d | 2012-11-05 A | 2013-01-14 A | 15221161 FS-69d | 100% | 2012-11-05 | 2012-12-31 | MECH TECH [11.61 h]; ELEC TECH [46.45 h] | 2,647.76 | 2,647.76 | 0 | 2647.7676 | CHUDAKOV | 1 | 1 |  | D |  | H | EUGENE C |  |  |  |  |  | 11-006 | 11-026 | 12-021F | 12-054F |  |  |  |  |  |  |  |  |  |  | APP | 5221C |  | IPL | 10-024 | 11-001 |  |  |  |  |  |  |  |  |  |  |  |  |  | XX | 12-053 | 11-054 |
| 15221057 | Installation BCAL Calibration System (BarCal) FY12 |  | 40d | 2013-01-07 A | 2013-07-15 A | 15221055a FS-20d, 15221055b | 100% | 2013-05-23 | 2013-07-19 | MECH TECH [79.62 h] | 3,651.37 | 3,651.37 | 636.896304 | 3538.3128 | CHUDAKOV | 1 | 1 |  | D |  | U | EUGENE C |  |  |  |  |  | 11-006 | 11-026 | 12-021 |  |  |  |  |  |  |  |  |  |  |  |  |  |  |  |  |  |  | 10-042 |  |  |  |  |  |  |  |  |  |  |  |  | 12-053 |  |
| 15221057a | Installation BCAL Calibration System (BarCal) FY13 |  | 45d | 2013-01-07 A | 2013-07-15 A | 15221057 FS-90d | 100% | 2013-02-01 | 2013-04-05 | MECH TECH [89.58 h] | 4,108.14 | 4,108.14 | 739.464984 | 4108.1388 | CHUDAKOV | 1 | 1 |  | D |  | U | EUGENE C |  |  |  |  |  | 11-006 | 11-026 | 12-021 |  |  |  |  |  |  |  |  |  |  |  |  |  |  |  |  |  |  | 10-042 |  |  |  |  |  |  |  |  |  |  |  |  | 12-053 |  |
| 15221057b | Installation BCAL Calibration System (BarCal) Procurements |  | 85d | 2013-01-07 A | 2013-08-30 A | 15221055b, 15221055a FS-20d | 100% | 2013-02-01 | 2013-06-03 | PROCUREMENT<$50K 60 NO ESCALATION FY13 | 21,189.87 |  | 12713.922 | 21189.87 | CHUDAKOV | 1 | 1 |  | D |  | D | EUGENE C |  |  |  |  |  | 11-006 | 11-026 | 12-021 |  |  |  |  |  | 0 | 21189.87 | 2118987 | 100 |  |  |  |  |  |  |  |  |  | 10-042 |  |  |  |  |  |  |  |  |  |  |  |  | 12-053 |  |
| 15221155a | Mechanical Support (BarCal) |  | 84d | 2013-01-28 A | 2013-02-11 A | 15221003, 9-120M FS+195d | 100% | 2013-02-01 | 2013-05-31 | SUPPLIES & MATERIALS | 10,648.18 |  | 0 | 10648.18 | CHUDAKOV | 1 | 1 |  | D |  | D | EUGENE C |  |  |  |  |  | 11-006 | 11-026 | 12-021F |  |  |  |  |  |  |  |  |  |  |  |  |  |  |  | 10-024 |  |  | 10-042 |  |  |  |  |  |  |  |  |  |  |  |  |  |  |

Notes:
- 15221003: Steps: Release Drawings for Light Guides (done); Design Cooling System (done); Design Mounting System (done); Design Light Tight Box (done); Release Drawing Package (done); Issue Purchase Req. (done)
- 15221018N: Corrective Actions: Deleted FY12 funding predecessor since it is applied to this activities / successor.
- 15221018P: Corrective Actions: Deleted FY12 funding predecessor since it is applied to this activities / successor.
- 15221160b: Explanation: IPL from 6 GeV 55221010 and 55221010c
- 15221157M: Explanation: IPL from 6 GeV 55221010 and 55221010c
- 15221158: Explanation: IPL from 6 GeV 55221010 and 55221010c
- 15221159: Explanation: IPL from 6 GeV 55221010 and 55221010c
- 15221159a: Explanation: IPL from 6 GeV 55221010 and 55221010c
- 15221159b: Explanation: IPL from 6 GeV 55221010 and 55221010c
- 15221160a: Explanation: IPL from 6 GeV 55221010 and 55221010c / Steps: Mech system concept (done); Mech integration concept (done); Mech FA temp stab (done); Mech FA light tightness (done); Mech FA structural design (done); Mech FA drawings and fabrication (done); Mech prototyping (done); Elec Bias concept (done); Elec Bias bench test (done); Elec Bias in situ testing (done); Elec Bias review (done); Elec PreA/Sum simulation (done); Elec PreA/Sum power (done); Elec PreA/Sum schematics (done); Elec PreA/Sum cabling (done); Elec PreA/Sum FA fab (done)
- 15221158b: Explanation: IPL from 6 GeV 55221010 and 55221010c
- 15221158a: Explanation: IPL from 6 GeV 55221010 and 55221010c
- 15221158M: Explanation: IPL from 6 GeV 55221010 and 55221010c
- 15221160ab: Explanation: IPL from 6 GeV 55221010 and 55221010c / Steps: Mech Prod Drawings (done); Elec Prod Drawings (done); Sytem integration (done); Preamp/summing board (1/3) (done); temp feedback/bias board (1/3) (done); Test setup (done); Test Preamp/sum board (done); Test Elec heat removal (done)
- 15221160ba: Explanation: IPL from 6 GeV 55221010 and 55221010c / Steps: Optics setup (done); Electronics setup (done); Mechanical setup (done); Readout electronics (done); Cables (done); Testing software (done); Receive inspection1 500 (done); Receive inspection2 500 (done); Receive inspection3 120 (done); Acceptance testing1 500 (done); Acceptance testing2 500 (done); Acceptance testing3 120 (done)
- 15221160baa: Explanation: IPL from 6 GeV 55221010 and 55221010c / Steps: Optics setup (done); Electronics setup (done); Mechanical setup (done); Readout electronics (done); Cables (done); Testing software (done); Receive inspection1 500 (done); Receive inspection2 500 (done); Receive inspection3 120 (done); Acceptance testing1 500 (done); Acceptance testing2 500 (done); Acceptance testing3 120 (done)
- 15221160bb: Explanation: IPL from 6 GeV 55221010 and 55221010c
- 15221020: Steps: Modules 1 - 40 (done); Modules 41 - 44 (done); Modules 45- 48 (done)
- 15221160aba: Explanation: IPL from 6 GeV 55221010 and 55221010c
- 15221161a: Explanation: IPL from 6 GeV 55221010 and 55221010c
- 15221161b: Explanation: IPL from 6 GeV 55221010 and 55221010c
- 15221161: Explanation: IPL from 6 GeV 55221010 and 55221010c
- 15221161c: Explanation: IPL from 6 GeV 55221010 and 55221010c
- 15221161f: Explanation: IPL from 6 GeV 55221010 and 55221010c
- 15221161h: Explanation: IPL from 6 GeV 55221010 and 55221010c
- 15221161j: Explanation: IPL from 6 GeV 55221010 and 55221010c
- 15221161k: Explanation: IPL from 6 GeV 55221010 and 55221010c
- 15221161n: Explanation: IPL from 6 GeV 55221010 and 55221010c
- 15221161s: Explanation: IPL from 6 GeV 55221010 and 55221010c

| ID | WBS | Activity | Duration | Start | Finish | Predecessors | Complete | Remaining | Planned start | Planned finish | Total float | Free float | Calendar | Resources | Cost | Actual cost | Remaining Material Cost Based on % Compl | Claimed Material Cost Based on % Complet | Initial Claimed Material Calc | Claimed Material Divider | Calculated Remaining Total Cost | MONTHLY EV COST | RESP - Responsibility | STRT%COMP for CM EVM | FNSH%COMP for CM EVM | HALL D Related Milestones | Profile change | EVMS Reporting Codes | CAM RESPONSIBLE | CR 09-043 | CR 10-042 | CR 11-006 | CR 11-026 | CR 12-021 | CR 12-055 | CR 12-054 | ReBaseline Actuals Adjustment | Original Activity ID Rebaseline | CR 09-014 | CR 13-007 | BOE Procurement | CR 13-015 | Post Rebaseline | Obligated Prior to Rebaseline | PRIOR MONTH EV COST | LOE % Pre Calc | LOE % | LOE Divider | LOE Multiplier | Activities with Steps | CR 12-053 | BOE Labor | CR 14-001 | BOE Expenses | CR 07-024 | CR 08-058 | 12 GeV 2nd level Critical Path | CR 09-027 | CR 09-027 Repair | Advance Purchase Plan > 500K | CR 08-060 | 12 GEV MAJOR PROCUREMENT CATAGORY | CR 10-007 | CR 09-012 | CR 08-016 | CR 10-002 | MARCH!!! | Specification | CR 10-009 |
| --- | --- | --- | --- | --- | --- | --- | --- | --- | --- | --- | --- | --- | --- | --- | --- | --- | --- | --- | --- | --- | --- | --- | --- | --- | --- | --- | --- | --- | --- | --- | --- | --- | --- | --- | --- | --- | --- | --- | --- | --- | --- | --- | --- | --- | --- | --- | --- | --- | --- | --- | --- | --- | --- | --- | --- | --- | --- | --- | --- | --- | --- | --- | --- | --- | --- | --- | --- | --- | --- |
| 15221180a |  | Proc Supprt Struct and assy tooling (BarCal) Part B | 120d | 2013-03-01 A | 2013-06-17 A | 9-120M FS-20d, 15221007 FS+280d, 15221008, 9-130M FS+81d | 100% |  | 2013-04-01 | 2013-09-18 |  |  |  | PROCUREMENT>$50K 69 | 11,000 |  | 0 | 11000 | 1100000 | 100 | 0 | 11000 | CHUDAKOV | 1 | 1 | D | C | D | EUGENE C | 09-043 | 10-042 | 11-006 | 11-026 | 12-021F | 12-055 |  |  |  |  |  |  |  |  |  |  |  |  |  |  |  |  |  |  |  |  |  |  |  |  |  |  |  |  |  |  |  |  |  |  |
| 15221182 |  | Procure BCAL SiPm chillers | 80d | 2013-03-04 A | 2013-06-17 A | 9-130M FS+110d | 100% |  | 2013-04-01 | 2013-07-23 |  |  |  | PROCUREMENT<$50K 60 | 24,765.6 |  | 0 | 24765.6 | 2476560 | 100 | 0 | 24765.6 | CHUDAKOV | 1 | 1 | D | C | D | EUGENE C |  |  |  |  | 12-021 |  | 12-054 |  |  |  |  |  |  |  |  |  |  |  |  |  |  |  |  |  |  |  |  |  |  |  |  |  |  |  |  |  |  |  |  |  |
| 15221315 |  | Re-Baseline Actuals Adjustment | 1d | 2013-08-30 A | 2013-08-30 A |  | 100% |  | 2013-09-03 | 2013-09-03 |  |  |  | PROCUREMENT>$50K 69 NO ESCALATION | 660,502.86 |  | 0 | 660502.86 | 66050286 | 100 |  | 660502.86 |  |  |  |  |  |  |  |  |  |  |  |  |  |  | ADJ |  |  |  |  |  |  |  |  |  |  |  |  |  |  |  |  |  |  |  |  |  |  |  |  |  |  |  |  |  |  |  |  |
| 25221000 |  | Regina contract Decommissioning | 43d | 2013-09-03 A | 2013-10-21 A | 9-130M FS+228d | 100% |  | 2013-10-01 | 2013-12-02 |  |  | 8/5 M-F w/JLAB Holidays ReBaseline | PROCUREMENT<$50K 60 NO ESCALATION FY14 | 8,478 |  | 0 | 8478 | 847800 | 100 |  | 8478 | CHUDAKOV | 1 | 1 | D |  | D | EUGENE C | 09-043 |  |  |  |  |  |  |  | 25221320 | 09-014 | 13-007 | EJ | 13-015 | PR | OB |  |  |  |  |  |  |  |  |  |  |  |  |  |  |  |  |  |  |  |  |  |  |  |  |  |
| 25221005 |  | Procured Labor (Designer) | 20d | 2013-09-03 A | 2013-12-02 | 9-130M FS+228d | 50% | 20d | 2013-10-01 | 2013-10-28 | 204d |  | 8/5 M-F w/JLAB Holidays ReBaseline | PROCUREMENT<$50K 60 | 1,142.1 |  | 571.05 | 571.05 | 57105 | 100 |  | 0 | CHUDAKOV | 1 | 1 | D |  | D | EUGENE C | 09-043 |  |  |  |  |  |  |  | 25221320 | 09-014 | 13-007 | EJ | 13-015 | PR | OB | 571.05 |  |  |  |  |  |  |  |  |  |  |  |  |  |  |  |  |  |  |  |  |  |  |  |  |
| 25221010 |  | Athens contract Completion | 43d | 2013-09-03 A | 2013-10-21 A | 9-130M FS+228d | 100% |  | 2013-10-01 | 2013-12-02 |  |  | 8/5 M-F w/JLAB Holidays ReBaseline | PROCUREMENT<$50K 60 NO ESCALATION FY14 | 5,125 |  | 0 | 5125 | 512500 | 100 |  | 5125 | CHUDAKOV | 1 | 1 | D |  | D | EUGENE C | 09-043 |  |  |  |  |  |  |  | 25221320 | 09-014 | 13-007 | EJ | 13-015 | PR | OB |  |  |  |  |  |  |  |  |  |  |  |  |  |  |  |  |  |  |  |  |  |  |  |  |  |
| 25221010LOE |  | Forklift Rental (ESB) | 43d | 2013-09-03 A | 2013-10-31 A | 9-130M FS+228d | 100% |  | 2013-10-01 | 2013-12-02 |  |  | 8/5 M-F w/JLAB Holidays ReBaseline | PROCUREMENT<$50K 60 NO ESCALATION FY14 | 816.67 |  | 0 | 816.67 | 81667 | 100 |  | 436.836783 | CHUDAKOV | 1 | 1 | D |  | E | EUGENE C | 09-043 |  |  |  |  |  |  |  | 25221320 | 09-014 | 13-007 | EJ | 13-015 | PR | OB | 379.833217 | 53.48837209 | 46.5116279 | 100 | 100 |  |  |  |  |  |  |  |  |  |  |  |  |  |  |  |  |  |  |  |  |
| 25221057b |  | Construction BCAL Pulsing System (BarCal) Labor FY13 | 62d | 2013-09-03 A | 2013-11-27 | 9-130M FS+228d | 25% | 19d | 2013-10-01 | 2014-01-08 | 194d | 41d | 8/5 M-F w/JLAB Holidays ReBaseline | ELEC ENG [23.23 h]; MECH TECH [11.61 h]; SCIENTIST [46.45 h] | 5,786.69 | 3,955.73 |  |  |  |  |  | 0 | CHUDAKOV | 1 | 1 | D |  | S | EUGENE C |  | 10-042 | 11-006 | 11-026 | 12-021 |  |  |  | 25221057b |  | 13-007F |  | 13-015 | PR |  | 1402.02024375 |  |  |  |  | ST | 12-053 | PE |  |  |  |  |  |  |  |  |  |  |  |  |  |  |  |  |  |
| 25221057ba |  | Construction BCAL Pulsing System (BarCal) Labor FY14 | 42d | 2013-09-03 A | 2013-11-27 | 25221057b FS-60d | 25% | 19d | 2013-10-01 | 2013-11-27 | 194d | 43d | 8/5 M-F w/JLAB Holidays ReBaseline | ELEC ENG [48.77 h]; MECH TECH [24.39 h]; SCIENTIST [97.55 h] | 12,152.11 | 8,307.09 |  |  |  |  |  | 0 | CHUDAKOV | 1 | 1 | D |  | S | EUGENE C |  | 10-042 | 11-006 | 11-026 | 12-021 |  |  |  | 25221057b |  | 13-007F |  | 13-015 | PR |  | 3038.0283205 |  |  |  |  | ST | 12-053 | PE | 14-001 |  |  |  |  |  |  |  |  |  |  |  |  |  |  |  |  |
| 25221057c |  | Construction BCAL Pulsing System (BarCal) Materials FY13 | 62d | 2013-09-03 A | 2013-10-21 A | 9-130M FS+228d | 100% |  | 2013-10-01 | 2014-01-08 |  |  | 8/5 M-F w/JLAB Holidays ReBaseline | SUPPLIES & MATERIALS | 532.26 |  |  |  |  |  |  | 106.452 | CHUDAKOV | 1 | 1 | D |  | D | EUGENE C |  | 10-042 | 11-006 | 11-026 | 12-021 |  |  |  | 25221057c |  | 13-007F |  | 13-015 | PR |  | 425.808 |  |  |  |  |  | 12-053 |  |  | EJ |  |  |  |  |  |  |  |  |  |  |  |  |  |  |  |
| 25221057ca |  | Construction BCAL Pulsing System (BarCal) Expenses FY14 | 42d | 2013-09-03 A | 2013-10-21 A | 25221057c FS-45d | 100% |  | 2013-10-01 | 2013-11-27 |  |  | 8/5 M-F w/JLAB Holidays ReBaseline | SUPPLIES & MATERIALS | 1,153.4 |  |  |  |  |  |  | 230.68 | CHUDAKOV | 1 | 1 | D |  | D | EUGENE C |  | 10-042 | 11-006 | 11-026 | 12-021 |  |  |  | 25221057c |  | 13-007F |  | 13-015 | PR |  | 922.72 |  |  |  |  |  | 12-053 |  | 14-001 | EJ |  |  |  |  |  |  |  |  |  |  |  |  |  |  |  |
| 25221320 |  | Procure BCAL cooling manifold | 23d | 2013-09-03 A | 2013-11-05 | 9-130M FS+228d | 90% | 3d | 2013-10-01 | 2013-10-31 | 54d | 20d | 8/5 M-F w/JLAB Holidays ReBaseline | PROCUREMENT<$50K 60 NO ESCALATION FY14 | 9,419.84 |  | 941.984 | 8477.856 | 847785.6 | 100 |  | 0 | CHUDAKOV | 1 | 1 | D |  | D | EUGENE C | 09-043 |  |  |  |  |  |  |  | 25221320 | 09-014 | 13-007 | EJ | 13-015 | PR | OB | 8477.856 |  |  |  |  |  |  |  |  |  |  |  |  |  |  |  |  |  |  |  |  |  |  |  |  |
| 25221060 |  | Setup and Testing of BCAL Pulsing System FY13 | 57d | 2013-12-05 | 2014-03-06 | 9-140M FS+45d, 9-130M FS+228d |  |  |  |  | 20d | 0d | 8/5 M-F w/JLAB Holidays ReBaseline | ELEC TECH [51.61 h]; ELEC ENG [51.61 h]; SCIENTIST [51.61 h] | 10,183.31 |  |  |  |  |  |  | 0 | CHUDAKOV | 1 | 1 | D |  | S | EUGENE C |  | 10-042 | 11-006 | 11-026 | 12-021 |  |  |  | 25221060 |  | 13-007F |  | 13-015 | PR |  |  |  |  |  |  |  | 12-053 | PE |  |  |  |  |  |  |  |  |  |  |  |  |  |  |  |  |  |
| 25221060a |  | Setup and Testing of BCAL Pulsing System FY14 | 57d | 2013-12-05 | 2014-03-06 | 25221060 FS-57d |  |  |  |  | 20d | 18d | 8/5 M-F w/JLAB Holidays ReBaseline | ELEC TECH [108.39 h]; ELEC ENG [108.39 h]; SCIENTIST [108.39 h] | 21,384.69 |  |  |  |  |  |  | 0 | CHUDAKOV | 1 | 1 | D |  | S | EUGENE C |  | 10-042 | 11-006 | 11-026 | 12-021 |  |  |  | 25221060 |  | 13-007F |  | 13-015 | PR |  |  |  |  |  |  |  | 12-053 | PE | 14-001 |  |  |  |  |  |  |  |  |  |  |  |  |  |  |  |  |
|  | 2 | **1.5.2.2.2 FORWARD CALORIMETER** |  | 2009-01-02 | 2014-01-16 |  |  |  |  |  |  |  |  |  |  |  |  |  |  |  |  |  |  |  |  |  |  |  |  |  |  |  |  |  |  |  |  |  |  |  |  |  |  |  |  |  |  |  |  |  |  |  |  |  |  |  |  |  |  |  |  |  |  |  |  |  |  |  |  |
| 15222009E |  | FY09 Travel (FWD CAL) | 189d | 2009-01-02 A | 2009-09-30 A | 15222009EX | 100% |  |  |  |  |  |  | TRAVEL | 646.88 |  |  |  |  |  | 0 | 646.88 | CHUDAKOV | 1 | 1 | D |  | E | EUGENE C |  |  | 11-006 | 11-026 |  |  | 12-054F |  |  |  |  |  |  |  |  |  |  |  | 100 | 100 |  |  |  |  |  | 07-024 | 08-058 |  |  |  |  |  |  |  |  |  |  |  |  |  |
| 15222001 |  | Prepare Procurements/Fabrication Packages 2009 (FWD CAL) | 158d | 2009-07-03 A | 2010-02-25 A | 9-090M FS+184d | 100% |  | 2009-07-06 | 2010-02-25 |  |  |  | MECH ENG [120 h]; MECH DES [240 h] | 18,531.69 | 18,531.69 |  |  |  |  | 0 | 18178.8 | CHUDAKOV | 1 | 1 | D |  | S | EUGENE C |  |  |  | 11-026 |  |  | 12-054F |  |  | 09-014 |  |  |  |  |  |  |  |  |  |  | ST |  |  |  |  | 07-024 |  | 2 | 09-027 | 09-027 |  |  |  |  |  |  |  |  |  |  |
| 15222010E |  | FY10 Travel (FWD CAL) | 248d | 2009-10-01 A | 2010-09-30 A | 15222009E | 100% |  |  |  |  |  |  | TRAVEL | 875.73 |  |  |  |  |  | 0 | 875.732254 | CHUDAKOV | 1 | 1 | D |  | E | EUGENE C |  |  | 11-006 | 11-026 |  |  | 12-054F |  |  |  |  |  |  |  |  |  |  |  | 100 | 100 |  |  |  |  |  | 07-024 |  |  |  |  |  |  |  |  |  |  |  |  |  |  |
| 15222003 |  | FY10 Engineering Support for Fabrication (FWD CAL) | 226d | 2009-11-02 A | 2010-09-30 A | 9-100M | 100% |  |  |  |  |  |  | MECH DES [80 h]; MECH ENG [80 h] | 8,887.2 | 8,887.2 |  |  |  |  | 0 | 8887.2 | CHUDAKOV | 1 | 1 | D |  | H | EUGENE C |  |  | 11-006 | 11-026 |  |  | 12-054F |  |  |  |  |  |  |  |  |  |  |  |  |  |  |  |  |  |  | 07-024 |  |  | 09-027 | 09-027 |  |  |  |  |  |  |  |  |  |  |
| 15222025 |  | Setup Divider Constrctn (FWD CAL) (Frozen by CR10-007) | 5d | 2009-12-14 A | 2009-12-21 A | 9-100M | 100% |  | 2009-12-14 | 2009-12-18 |  |  |  | ELEC ENG [328 h] | 21,736.56 | 21,736.56 |  |  |  |  | 0 | 21736.56 | CHUDAKOV | 1 | 1 | D |  | S | EUGENE C |  |  |  |  |  |  |  |  |  |  |  |  |  |  |  |  |  |  |  |  | NB |  |  |  |  |  |  |  |  |  | APP | 08-060 | 5222 | 10-007 |  |  |  |  |  |  |
| 15222045 |  | Setup Procedure & Glue LG to PMT's (FWD CAL) (Frozen by CR10-007) | 5d | 2009-12-14 A | 2009-12-21 A | 9-100M FS+30d | 100% |  | 2009-12-14 | 2009-12-18 |  |  |  | CONTRB UNIV LBR [50.4 h]; VISTNG USERS [84 h] | 1,524.6 | 1,524.6 |  |  |  |  | 0 | 1524.6 | CHUDAKOV | 1 | 1 | D |  | H | EUGENE C |  |  |  | 11-026 |  |  | 12-054F |  |  |  |  |  |  |  |  |  |  |  |  |  |  |  |  |  |  |  |  |  |  |  | APP | 08-060 | 5222 | 10-007 |  |  |  |  |  |  |
| 15222050 |  | Proc Magnetic Shields (FWD CAL) (Frozen by CR10-007) | 5d | 2009-12-14 A | 2009-12-21 A | 15222001, 12322018M, 9-100M | 100% |  | 2009-12-14 | 2009-12-18 |  |  |  | PROCUREMENT<$50K 60 | 61,531.98 |  | 0 | 61531.98 | 6153198 | 100 | 0 | 61531.98 | CHUDAKOV | 1 | 1 | D |  | H | EUGENE C |  |  |  | 11-026 |  |  | 12-054F |  |  |  |  |  |  |  |  |  |  |  |  |  |  |  |  |  |  |  |  |  | 09-027 | 09-027 | APP | 08-060 | 5222 | 10-007 |  |  |  |  |  |  |
| 15222110 |  | Reverse Entry Per CR10-007 | 5d | 2009-12-14 A | 2009-12-21 A | 9-100M FS+45d | 100% |  | 2009-12-14 | 2009-12-18 |  |  |  | VISTNG USERS [-84 h]; PROCUREMENT<$50K 60; CONTRB UNIV LBR [-50.4 h]; ELEC ENG [-328 h] | -84,793.14 | -23,261.16 |  |  |  | 100 |  |  | CHUDAKOV | 1 | 1 | D |  | H | EUGENE C |  |  |  |  |  |  |  |  |  | 09-014 |  |  |  |  |  |  |  |  |  |  |  |  |  |  |  |  |  |  |  |  |  |  |  | 10-007 |  |  |  |  |  |  |
| 15222015 |  | Proc Replacement PMTs (FWD CAL) | 207d | 2010-02-01 A | 2010-11-22 A | 9-090M FS+184d, 12322018M | 100% |  |  |  |  |  |  | PROCUREMENT<$50K 60 NO ESCALATION FY10; PROCUREMENT>$50K 69 NO ESCALATION FY10 | 85,185.41 |  | 0 | 85185.41 | 8518541 | 100 | 0 | 85185.41 | CHUDAKOV | 1 | 1 | D |  | D | EUGENE C |  |  |  | 11-026 |  |  | 12-054F |  |  |  |  |  |  |  |  |  |  |  |  |  |  |  |  |  |  |  |  |  |  |  |  | 08-060 |  |  | 09-012 |  |  |  |  |  |
| 15222002 |  | Prepare Procurements/Fabrication Packages 2010 (FWD CAL) | 322d | 2010-02-08 A | 2011-05-23 A | 9-100M FS+184d | 100% |  |  |  |  |  |  | MECH ENG [160 h]; MECH DES [400 h] | 29,076.67 | 29,076.67 |  |  |  |  | 0 | 28632 | CHUDAKOV | 1 | 1 | D |  | S | EUGENE C |  |  | 11-006 | 11-026 |  |  | 12-054F |  |  | 09-014 |  |  |  |  |  |  |  |  |  |  | ST |  |  |  |  | 07-024 |  | 2 | 09-027 | 09-027 |  |  |  |  |  |  |  |  |  |  |
| 15222011E |  | FY11 Travel (FWD CAL) | 248d | 2010-10-01 A | 2011-09-30 A | 15222010E | 100% |  |  |  |  |  |  | TRAVEL | 902.21 |  |  |  |  |  | 0 | 902.21 | CHUDAKOV | 1 | 1 | D |  | E | EUGENE C |  |  | 11-006 | 11-026 |  |  | 12-054F |  |  |  |  |  |  |  |  |  | 8.46774193 | 91.53225806 | 100 | 100 |  |  |  |  |  | 07-024 |  |  |  |  |  |  |  | 10-007 |  |  |  |  |  |  |
| 15222055 |  | Proc Pb Glass Insert PR | 14d | 2011-01-04 A | 2011-01-24 A | 9-110M FS+78d | 100% |  |  |  |  |  |  | SCIENTIST [80 h] | 5,474.4 | 5,474.4 |  |  |  |  | 0 | 5474.4 | CHUDAKOV | 1 | 1 | D |  | H | EUGENE C |  |  | 11-006 | 11-026 |  |  | 12-054F |  |  |  |  |  |  |  |  |  |  |  |  |  |  |  |  |  |  |  |  |  | 09-027 | 09-027 | APP | 08-060 | 5222 | 10-007 |  |  |  |  |  |  |
| 15222060 |  | Proc Pb Glass Insert | 14d | 2011-01-04 A | 2011-01-24 A | 15222055 | 100% |  |  |  |  |  |  |  |  |  |  |  |  |  |  | 0 | CHUDAKOV | 1 | 1 | D |  | Z | EUGENE C |  |  | 11-006 | 11-026 |  |  | 12-054F |  |  |  |  |  |  |  |  |  |  |  |  |  |  |  |  |  |  |  |  |  | 09-027 | 09-027 | APP | 08-060 | 5222 | 10-007 |  |  |  |  |  |  |
| 15222007 |  | FY11 Engineering Support for Fabrication (FWD CAL) | 188d | 2011-01-05 A | 2011-09-30 A | 9-110M FS+60d | 100% |  |  |  |  |  |  | MECH ENG [160 h]; MECH DES [320 h] | 25,809.6 | 25,809.6 |  |  |  |  | 0 | 25809.6 | CHUDAKOV | 1 | 1 | D |  | E | EUGENE C |  |  | 11-006 | 11-026 |  |  | 12-054F |  |  |  |  |  |  |  |  |  | 11.17021276 | 88.82978723 | 100 | 100 |  |  |  |  |  |  |  | 2 |  |  |  |  |  |  |  |  |  |  |  |  |
| 15222004 |  | Prep Support Struc Procurement Package 2011(FWD CAL) | 65d | 2011-06-30 A | 2011-09-30 A | 15222003, 15222002, 9-110M FS+183d | 100% |  |  |  |  |  |  | MECH ENG [120 h]; MECH DES [160 h] | 15,622.8 | 15,622.8 |  |  |  |  | 0 | 15622.8 | CHUDAKOV | 1 | 1 | D |  | E | EUGENE C |  |  | 11-006 | 11-026 |  |  | 12-054F |  |  |  |  |  |  |  |  |  | 67.69230769 | 32.3076923 | 100 | 100 |  |  |  |  |  | 07-024 |  |  | 09-027 | 09-027 |  |  |  |  |  |  |  |  |  |  |
| 15222012E |  | FY12 Travel (FWD CAL) | 58d | 2011-10-03 A | 2011-12-30 A | 15222011E | 100% |  |  |  |  |  |  | TRAVEL | 187.2 |  |  |  |  |  | 0 | 187.2 | CHUDAKOV | 1 | 1 | D |  | E | EUGENE C |  |  | 11-006 | 11-026 |  |  | 12-054F |  |  |  |  |  |  |  |  |  | 29.31034482 | 70.68965517 | 100 | 100 |  |  |  |  |  | 07-024 |  |  |  |  |  |  |  |  |  |  |  |  |  |  |
| 15222080 |  | Fabricate FCAL Monitoring System (FWD CAL) | 283d | 2011-12-01 A | 2013-05-13 A | 1152055, 9-120M FS+60d | 100% |  | 2011-12-01 | 2013-01-28 |  |  |  | PROCUREMENT<$50K 60; MECH TECH [144 h] | 33,075.44 | 6,485.85 | 0 | 26620.44 | 2662044 | 100 | 0 | 33019.8 | CHUDAKOV | 1 | 1 | D |  | U | EUGENE C |  | 10-042 | 11-006 | 11-026 |  |  | 12-054F |  |  |  |  |  |  |  |  |  |  |  |  |  |  |  |  |  |  |  |  |  |  |  | APP | 08-060 | 5222 |  | 09-012 | 08-016 | 10-002 | XX |  |  |
| 15222005 |  | FY12 Engineering Support for Fabrication (FWD CAL) | 117d | 2012-04-16 A | 2012-09-28 A | 15222007 FS-20d, 9-120M FS+130d | 100% |  |  |  |  |  |  | MECH DES [114.85 h] | 5,532.32 | 5,532.32 |  |  |  |  | 0 | 5532.3245 | CHUDAKOV | 1 | 1 | D |  | E | EUGENE C |  |  | 11-006 | 11-026 |  |  | 12-054F |  |  |  |  |  |  |  |  |  | 16.23931623 | 83.76068376 | 100 | 100 |  |  |  |  |  | 07-024 |  |  | 09-027 | 09-027 |  |  |  | 10-007 |  |  |  |  |  |  |
| 15222006 |  | FY13 Engineering Support for Fabrication (FWD CAL) | 204d | 2012-10-01 A | 2013-07-29 A | 15222005, 9-130M | 100% |  |  |  |  |  |  | MECH ENG [33.95 h]; MECH DES [203.67 h] | 12,581.06 | 12,581.06 |  |  |  |  | 0 | 12581.0577 | CHUDAKOV | 1 | 1 | D |  | E | EUGENE C |  |  | 11-006 | 11-026 |  |  | 12-054F |  |  | 09-014 |  |  |  |  |  |  | 9.80392156 | 90.19607843 | 100 | 100 |  |  |  |  |  | 07-024 |  | 2 | 09-027 | 09-027 |  |  |  | 10-007 |  |  |  |  |  |  |
| 15222100 |  | Stacking of Blocks (FWD CAL) FY12 | 233d | 2013-01-07 A | 2013-01-28 A | 15222006 FS-155d, 15222060 | 100% |  | 2013-02-01 | 2014-01-09 |  |  |  | CONTRB UNIV LBR [340.87 h]; MECH TECH [340.87 h] | 15,771.13 | 15,632.3 |  |  |  |  | 0 | 15148.2628 | CHUDAKOV | 1 | 1 | D |  | U | EUGENE C |  |  | 11-006 | 11-026 |  |  | 12-054F |  |  | 09-014 |  |  |  |  |  |  |  |  |  |  |  | 12-053 |  |  |  |  |  |  |  |  |  |  |  |  |  |  |  |  | 15222100 |  |
| 15222100a |  | Stacking of Blocks (FWD CAL) FY13 | 233d | 2013-01-07 A | 2013-06-17 A | 15222100 FS-233d | 100% |  | 2013-02-01 | 2014-01-09 |  |  |  | CONTRB UNIV LBR [1419.13 h]; MECH TECH [1419.13 h] | 65,659.31 | 65,081.3 |  |  |  |  | 0 | 65081.3018 | CHUDAKOV | 1 | 1 | D |  | U | EUGENE C |  |  | 11-006 | 11-026 |  |  | 12-054F |  |  | 09-014 |  |  |  |  |  |  |  |  |  |  |  | 12-053 |  |  |  |  |  |  |  |  |  |  |  |  |  |  |  |  | 15222100 |  |
| 15222105 |  | Assy of Single Channel FCal Detector (FWD CAL) | 233d | 2013-01-07 A | 2013-06-17 A | 195222285 FS-110d, 15222015, 15222045, 15222050, 9-130M FS+30d | 100% |  | 2013-02-01 | 2014-01-09 |  |  |  | MECH TECH [880 h]; CONTRB UNIV LBR [1760 h] | 40,715.22 | 40,356.8 |  |  |  |  | 0 | 40356.8 | CHUDAKOV | 1 | 1 | D |  | U | EUGENE C |  | 10-042 | 11-006 | 11-026 |  |  | 12-054 |  |  | 09-014 |  |  |  |  |  |  |  |  |  |  |  |  |  |  |  |  |  |  |  |  |  |  |  | 10-007 |  |  |  |  |  | 10-009 |
| 15222115 |  | Re-Baseline Actuals Adjustment | 1d | 2013-08-30 A | 2013-08-30 A |  | 100% |  | 2013-09-03 | 2013-09-03 |  |  |  | PROCUREMENT>$50K 69 NO ESCALATION | -95,164.67 |  |  |  |  | 100 |  |  |  |  |  |  |  |  |  |  |  |  |  |  |  |  | ADJ |  |  |  |  |  |  |  |  |  |  |  |  |  |  |  |  |  |  |  |  |  |  |  |  |  |  |  |  |  |  |  |  |
| 25222085 |  | Fabricate and Install Monitoring Panes (FCAL) FY13 | 20d | 2013-09-03 A | 2014-01-16 | 9-130M FS+228d | 80% | 45d | 2013-10-01 | 2013-10-28 | 122d | 35d | 8/5 M-F w/JLAB Holidays ReBaseline | SCIENTIST [27.27 h]; MECH ENG [4.55 h]; MECH DES [9.09 h]; SUPPLIES & MATERIALS; MECH TECH [36.36 h] | 5,140.35 | 2,204.23 |  |  |  |  |  | 1499.708673 | CHUDAKOV | 1 | 1 | D |  | S | EUGENE C |  | 10-042 | 11-006 | 11-026 |  |  | 12-054F |  | 25222085 |  | 13-007 |  | 13-015 | PR |  | 2499.514455 |  |  |  |  | ST |  | EJ |  | EJ |  |  |  |  |  | APP | 08-060 | 5222 |  | 09-012 | 08-016 | 10-002 |  |  |  |
| 25222085a |  | Fabricate and Install Monitoring Panes (FCAL) FY14 | 68d | 2013-09-03 A | 2014-01-16 | 25222085 FS-80d | 80% | 45d | 2013-10-01 | 2014-01-16 | 122d | 43d | 8/5 M-F w/JLAB Holidays ReBaseline | SCIENTIST [92.72 h]; MECH ENG [15.45 h]; MECH DES [30.91 h]; SUPPLIES & MATERIALS; MECH TECH [123.63 h] | 17,538.39 | 7,494.42 |  |  |  |  |  | 5261.5186836 | CHUDAKOV | 1 | 1 | D |  | S | EUGENE C |  | 10-042 | 11-006 | 11-026 |  |  | 12-054F |  | 25222085 |  | 13-007 |  | 13-015 | PR |  | 8769.197806 |  |  |  |  | ST |  | EJ | 14-001 | EJ |  |  |  |  |  | APP | 08-060 | 5222 |  | 09-012 | 08-016 | 10-002 |  |  |  |
| 25222090 |  | Fabricate and Install Monitoring Panes (FCAL) (Previously Obligated) | 88d | 2013-09-03 A | 2013-09-23 A | 9-130M FS+228d | 100% |  | 2013-10-01 | 2014-02-14 |  |  | 8/5 M-F w/JLAB Holidays ReBaseline | PROCUREMENT<$50K 60 NO ESCALATION FY14 | 5,520 |  | 0 | 5520 | 552000 | 100 |  | 0 | CHUDAKOV | 1 | 1 | D |  | D | EUGENE C |  | 10-042 | 11-006 | 11-026 |  |  | 12-054F |  | 25222085 |  | 13-007 |  | 13-015 | PR | OB | 5520 |  |  |  |  |  |  | EJ |  | EJ |  |  |  |  |  | APP | 08-060 | 5222 |  | 09-012 | 08-016 | 10-002 |  |  |  |

Notes:
- 25221057b: Steps: Pulse logic (done); Pulse implementation; Pulse distribution; Testing of farm manager in Counting House
- 25221057ba: Steps: Pulse logic (done); Pulse implementation; Pulse distribution; Testing of farm manager in Counting House
- 15222001: Steps: Release Drawing for Magnetic Shields (done); Perform Magnetic Shield Tests (done); Release Specification For Replacement PMT's (done); Release Drawing for Support Straps (done)
- 15222025: Explanation: See Change Request # 10-007
- 15222002: Steps: Release Drawings for Light Guides (done); Release Drawing For Support Structure (done); Complete Analysis for Support Structure (done)
- 25222085: Steps: Machine 4 panels (done); install hardware (done); sand/paint panels (done); release dwgs (done); Glue LEDs; Install panels
- 25222085a: Steps: Machine 4 panels (done); install hardware (done); sand/paint panels (done); release dwgs (done); Glue LEDs; Install panels

| ID | WBS | Activity | Duration | Start | Finish | Predecessors | Complete | Remaining | Planned start | Planned finish | Total float | Free float | Calendar | Resources | Cost | Actual cost | Remaining Material Cost Based on % Compl | Claimed Material Cost Based on % Complet | Initial Claimed Material Calc | Claimed Material Divider | Calculated Remaining Total Cost | MONTHLY EV COST | RESP - Responsibility | STRT%COMP for CM EVM | FNSH%COMP for CM EVM | HALL D Related Milestones | EVMS Reporting Codes | CAM RESPONSIBLE | CR 10-042 | CR 11-026 | CR 12-021 | CR 12-054 | LOE % Pre Calc | LOE % | LOE Divider | LOE Multiplier | CR 07-024 | 12 GeV 2nd level Critical Path | CR 09-014 | CR 09-027 | CR 09-027 Repair | CR 11-006 | MARCH!!! | CR 09-012 | CR 12-049 | CR 12-053 | ReBaseline Actuals Adjustment | Original Activity ID Rebaseline | PRIOR MONTH EV COST | CR 13-007 | BOE Labor | CR 13-015 | Post Rebaseline | BOE Procurement | Obligated Prior to Rebaseline | CR 14-001 |
| --- | --- | --- | --- | --- | --- | --- | --- | --- | --- | --- | --- | --- | --- | --- | --- | --- | --- | --- | --- | --- | --- | --- | --- | --- | --- | --- | --- | --- | --- | --- | --- | --- | --- | --- | --- | --- | --- | --- | --- | --- | --- | --- | --- | --- | --- | --- | --- | --- | --- | --- | --- | --- | --- | --- | --- | --- |
|  | 3 | **1.5.2.2.3 UPSTREAM PHOTON VETO** |  |  |  |  |  |  |  |  |  |  |  |  |  |  |  |  |  |  |  |  |  |  |  |  |  |  |  |  |  |  |  |  |  |  |  |  |  |  |  |  |  |  |  |  |  |  |  |  |  |  |  |  |  |  |
|  | 3 | **1.5.2.3 PARTICLE ID** |  | 2010-06-30 | 2014-01-31 |  |  |  |  |  |  |  |  |  |  |  |  |  |  |  |  |  |  |  |  |  |  |  |  |  |  |  |  |  |  |  |  |  |  |  |  |  |  |  |  |  |  |  |  |  |  |  |  |  |  |  |
|  | 1 | **1.5.2.3.1 TIME OF FLIGHT** |  | 2010-06-30 | 2014-01-31 |  |  |  |  |  |  |  |  |  |  |  |  |  |  |  |  |  |  |  |  |  |  |  |  |  |  |  |  |  |  |  |  |  |  |  |  |  |  |  |  |  |  |  |  |  |  |  |  |  |  |  |
| 15231019 |  | Proc First Article PMTs (TOF) | 66d | 2010-06-30 A | 2010-10-01 A | 9-100M FS+205d | 100% |  |  |  |  |  |  | PROCUREMENT<$50K 60 | 12,000 |  | 0 | 12000 | 1200000 | 100 | 0 | 12000 | CHUDAKOV | 1 | 1 | D | P | EUGENE C | 10-042 | 11-026 | 12-021F | 12-054F |  |  |  |  |  |  |  |  |  |  |  |  |  |  |  |  |  |  |  |  |  |  |  |  |
| 15231011E |  | FY11 Travel (TOF) | 248d | 2010-10-01 A | 2011-09-30 A | 9-110M | 100% |  |  |  |  |  |  | TRAVEL | 1,606.65 |  |  |  |  |  | 0 | 1606.65 | CHUDAKOV | 1 | 1 | D | E | EUGENE C |  | 11-026 |  | 12-054F | 8.46774193 | 91.53225806 | 100 | 100 | 07-024 |  |  |  |  |  |  |  |  |  |  |  |  |  |  |  |  |  |  |  |
| 15231001 |  | Prepare Procurements/Fabrication Packages 2011 (TOF) | 64d | 2011-07-01 A | 2011-09-30 A | 9-110M FS+162d | 100% |  |  |  |  |  |  | MECH ENG [40 h]; MECH DES [760 h] | 38,194.8 | 38,194.8 |  |  |  |  | 0 | 38194.8 | CHUDAKOV | 1 | 1 | D | E | EUGENE C |  | 11-026 | 12-021F | 12-054F | 0 |  | 100 | 100 | 07-024 | 2 | 09-014 | 09-027 | 09-027 | 11-006 |  |  |  |  |  |  |  |  |  |  |  |  |  |  |
| 15231001a |  | Prepare Procurements/Fabrication Packages 2012 (TOF) | 127d | 2011-10-03 A | 2012-04-10 A | 15231001 | 100% |  |  |  |  |  |  | MECH ENG [40 h]; MECH DES [760 h] | 39,414 | 39,414 |  |  |  |  | 0 | 39414 | CHUDAKOV | 1 | 1 | D | E | EUGENE C |  | 11-026 | 12-021F | 12-054F | 5.51181102 | 94.48818897 | 100 | 100 | 07-024 | 2 | 09-014 | 09-027 | 09-027 | 11-006 |  |  |  |  |  |  |  |  |  |  |  |  |  |  |
| 15231012E |  | FY12 Travel (TOF) | 247d | 2011-10-03 A | 2012-09-28 A | 15231011E | 100% |  |  |  |  |  |  | TRAVEL | 1,657.9 |  |  |  |  |  | 0 | 1657.9 | CHUDAKOV | 1 | 1 | D | E | EUGENE C |  | 11-026 |  | 12-054F | 7.69230769 | 92.3076923 | 100 | 100 | 07-024 |  |  |  |  |  |  |  |  |  |  |  |  |  |  |  |  |  |  |  |
| 15231002 |  | Engineering Support for Testing 2012 | 156d | 2012-05-14 A | 2013-02-11 A | 9-120M FS+160d | 100% |  | 2012-05-14 | 2012-12-31 |  |  |  | MECH ENG [80 h]; MECH DES [80 h] | 9,577.56 | 9,606.18 |  |  |  |  | 0 | 9463.2 | CHUDAKOV | 1 | 1 | D | H | EUGENE C |  | 11-026 | 12-021F | 12-054F |  |  |  |  | 07-024 | 2 | 09-014 | 09-027 | 09-027 |  | XX |  |  |  |  |  |  |  |  |  |  |  |  |  |
| 15231020 |  | Proc PMTs (TOF) | 194d | 2012-06-02 A | 2013-02-11 A | 12323040M, 9-120M FS+163d, 15231019 | 100% |  | 2012-06-05 | 2013-03-18 |  |  |  | PROCUREMENT<$50K 60; PROCUREMENT>$50K 69 | 147,828.89 |  | 0 | 147828.89 | 14782889 | 100 | 0 | 147828.89 | CHUDAKOV | 1 | 1 | D | D | EUGENE C | 10-042 | 11-026 | 12-021 | 12-054F |  |  |  |  |  |  |  |  |  |  |  |  |  |  |  |  |  |  |  |  |  |  |  |  |
| 15231025 |  | Proc Dividers (TOF) | 194d | 2012-06-02 A | 2013-02-11 A | 9-120M FS+163d, 12323040M | 100% |  | 2012-06-05 | 2013-03-18 |  |  |  | PROCUREMENT<$50K 60 | 31,385.4 |  | 0 | 31385.4 | 3138540 | 100 | 0 | 31385.4 | CHUDAKOV | 1 | 1 | D | D | EUGENE C |  | 11-026 | 12-021 | 12-054F |  |  |  |  |  |  |  |  |  |  |  | 09-012 |  |  |  |  |  |  |  |  |  |  |  |  |
| 15231075 |  | FSU - Scintillator Procurement Part E | 225d | 2012-09-04 A | 2013-03-11 A | 1152055, 9-120M FS+228d | 100% |  | 2012-09-04 | 2013-07-31 |  |  |  | PROCUREMENT<$50K 60 NO ESCALATION; PROCUREMENT>$50K 69 NO ESCALATION | 75,648.59 |  | 0 | 75648.59 | 7564859 | 100 | 0 | 75648.59 | CHUDAKOV | 1 | 1 | D | D | EUGENE C |  | 11-026 | 12-021 |  |  |  |  |  |  |  |  | 09-027 | 09-027 | 11-006 |  |  | 12-049 |  |  |  |  |  |  |  |  |  |  |  |
| 15231080 |  | FSU - Light Guide Material Procurement | 225d | 2012-09-04 A | 2013-03-11 A | 15231075 FS-225d | 100% |  | 2012-09-04 | 2013-07-31 |  |  |  | PROCUREMENT>$50K 69 NO ESCALATION | 17,856 |  | 0 | 17856 | 1785600 | 100 | 0 | 17856 | CHUDAKOV | 1 | 1 | D | D | EUGENE C |  | 11-026 | 12-021 |  |  |  |  |  |  |  |  | 09-027 | 09-027 | 11-006 |  |  | 12-049 |  |  |  |  |  |  |  |  |  |  |  |
| 15231090 |  | FSU - Proc Supplies (TOF) Part B | 225d | 2012-09-04 A | 2013-08-30 A | 15231080 FS-225d | 100% |  | 2012-09-04 | 2013-07-31 |  |  |  | PROCUREMENT>$50K 69 NO ESCALATION | 9,784.94 |  | 0 | 9784.94 | 978494 | 100 | 5381.717 | 9784.94 | CHUDAKOV | 1 | 1 | D | D | EUGENE C |  | 11-026 | 12-021 |  |  |  |  |  |  |  |  |  |  | 11-006 |  |  | 12-049 |  |  |  |  |  |  |  |  |  |  |  |
| 15231093 |  | FSU - Jig Construction | 82d | 2012-09-04 A | 2013-08-15 A | 15231090 FS-225d | 100% |  | 2012-09-04 | 2013-01-07 |  |  |  | PROCUREMENT>$50K 69 NO ESCALATION | 18,523.51 |  | 0 | 18523.51 | 1852351 | 100 | 555.7053 | 18523.51 | CHUDAKOV | 1 | 1 | D | D | EUGENE C |  |  |  |  |  |  |  |  |  |  |  |  |  |  | XX |  | 12-049 |  |  |  |  |  |  |  |  |  |  |  |
| 15231095 |  | FSU - Polishing and Gluing of First 30 Units | 183d | 2012-09-04 A | 2013-06-17 A | 15231093 FS-62d | 100% |  | 2012-09-04 | 2013-05-31 |  |  |  | PROCUREMENT>$50K 69 NO ESCALATION | 16,382.87 |  | 0 | 16382.87 | 1638287 | 100 | 0 | 16382.87 | CHUDAKOV | 1 | 1 | D | D | EUGENE C |  |  |  |  |  |  |  |  |  |  |  |  |  |  |  |  | 12-049 |  |  |  |  |  |  |  |  |  |  |  |
| 15231100 |  | FSU - Wrapping of First 30 Units | 183d | 2012-09-04 A | 2013-07-15 A | 15231095 FS-183d | 100% |  | 2012-09-04 | 2013-05-31 |  |  |  | PROCUREMENT>$50K 69 NO ESCALATION | 9,014.5 |  | 0 | 9014.5 | 901450 | 100 | 3605.8 | 9014.5 | CHUDAKOV | 1 | 1 | D | D | EUGENE C |  |  |  |  |  |  |  |  |  |  |  |  |  |  |  |  | 12-049 |  |  |  |  |  |  |  |  |  |  |  |
| 15231105 |  | FSU - Mount PMT and Testing of First 30 Units | 183d | 2012-09-04 A | 2013-08-30 A | 15231100 FS-183d | 100% |  | 2012-09-04 | 2013-05-31 |  |  |  | PROCUREMENT>$50K 69 NO ESCALATION | 18,739.86 |  | 0 | 18739.86 | 1873986 | 100 | 14054.895 | 18739.86 | CHUDAKOV | 1 | 1 | D | D | EUGENE C |  |  |  |  |  |  |  |  |  |  |  |  |  |  |  |  | 12-049 |  |  |  |  |  |  |  |  |  |  |  |
| 15231110 |  | FSU - Polishing and Gluing of Second 30 Units | 247d | 2012-09-04 A | 2013-07-15 A | 15231105 FS-183d | 100% |  | 2012-09-04 | 2013-08-30 |  |  |  | PROCUREMENT>$50K 69 NO ESCALATION | 16,382.87 |  | 0 | 16382.87 | 1638287 | 100 | 1474.4583 | 16382.87 | CHUDAKOV | 1 | 1 | D | D | EUGENE C |  |  |  |  |  |  |  |  |  |  |  |  |  |  |  |  | 12-049 |  |  |  |  |  |  |  |  |  |  |  |
| 15231115 |  | FSU - Wrapping of Second 30 Units | 247d | 2012-09-04 A | 2013-08-30 A | 15231110 FS-247d | 100% |  |  |  |  |  |  | PROCUREMENT>$50K 69 NO ESCALATION | 9,014.5 |  | 0 | 9014.5 | 901450 | 100 | 9014.5 | 9014.5 | CHUDAKOV | 1 | 1 | D | D | EUGENE C |  |  |  |  |  |  |  |  |  |  |  |  |  |  |  |  | 12-049 |  |  |  |  |  |  |  |  |  |  |  |
| 15231120 |  | FSU - Mount PMT and Testing of Second 30 Units | 247d | 2012-09-04 A | 2013-08-30 A | 15231115 FS-247d | 100% |  |  |  |  |  |  | PROCUREMENT>$50K 69 NO ESCALATION | 18,739.86 |  | 0 | 18739.86 | 1873986 | 100 | 14054.895 | 18739.86 | CHUDAKOV | 1 | 1 | D | D | EUGENE C |  |  |  |  |  |  |  |  |  |  |  |  |  |  |  |  | 12-049 |  |  |  |  |  |  |  |  |  |  |  |
| 15231015 |  | FSU - Proc Supplies (TOF) Part A | 222d | 2012-09-07 A | 2013-06-17 A | 9-120M FS+205d, 12323040M | 100% |  | 2012-09-07 | 2013-07-31 |  |  |  | PROCUREMENT>$50K 69 | 11,700.06 |  | 0 | 11700.06 | 1170006 | 100 | 0 | 11700.06 | CHUDAKOV | 1 | 1 | D | D | EUGENE C |  | 11-026 | 12-021F | 12-054F |  |  |  |  |  |  |  |  |  |  |  |  |  |  |  |  |  |  |  |  |  |  |  |  |
| 15231055 |  | FSU - Scintillator Procurement Part A | 222d | 2012-09-07 A | 2012-12-17 A | 9-120M FS+227d | 100% |  | 2012-09-07 | 2013-07-31 |  |  |  | PROCUREMENT<$50K 60 NO ESCALATION | 284.53 |  | 0 | 284.53 | 28453 | 100 | 0 | 284.53 | CHUDAKOV | 1 | 1 | D | D | EUGENE C |  | 11-026 | 12-021 |  |  |  |  |  |  |  |  |  |  |  |  |  | 12-049 | 12-053 |  |  |  |  |  |  |  |  |  |  |
| 15231060 |  | FSU - Scintillator Procurement Part B | 222d | 2012-09-07 A | 2013-03-11 A | 9-120M FS+197d | 100% |  | 2012-09-07 | 2013-07-31 |  |  |  | PROCUREMENT<$50K 60 NO ESCALATION | 2,745.98 |  | 0 | 2745.98 | 274598 | 100 | 0 | 2745.98 | CHUDAKOV | 1 | 1 | D | D | EUGENE C |  | 11-026 | 12-021 |  |  |  |  |  |  |  |  |  |  |  |  |  | 12-049 | 12-053 |  |  |  |  |  |  |  |  |  |  |
| 15231065 |  | FSU - Scintillator Procurement Part C | 222d | 2012-09-07 A | 2013-03-11 A | 9-120M FS+202d | 100% |  | 2012-09-07 | 2013-07-31 |  |  |  | PROCUREMENT<$50K 60 NO ESCALATION | 3,051.62 |  | 0 | 3051.62 | 305162 | 100 | 0 | 3051.62 | CHUDAKOV | 1 | 1 | D | D | EUGENE C |  | 11-026 | 12-021 |  |  |  |  |  |  |  |  |  |  |  |  |  | 12-049 | 12-053 |  |  |  |  |  |  |  |  |  |  |
| 15231070 |  | FSU - Scintillator Procurement Part D | 222d | 2012-09-07 A | 2013-03-11 A | 9-120M FS+190d | 100% |  | 2012-09-07 | 2013-07-31 |  |  |  | PROCUREMENT<$50K 60 NO ESCALATION | 5,489.28 |  | 0 | 5489.28 | 548928 | 100 | 0 | 5489.28 | CHUDAKOV | 1 | 1 | D | D | EUGENE C |  | 11-026 | 12-021 |  |  |  |  |  |  |  |  |  |  |  |  |  | 12-049 | 12-053 |  |  |  |  |  |  |  |  |  |  |
| 15231013E |  | FY13 Travel (TOF) | 120d | 2012-10-01 A | 2013-03-29 A | 15231012E, 15222012E | 100% |  |  |  |  |  |  | TRAVEL | 683.36 |  |  |  |  |  | 0 | 683.36 | CHUDAKOV | 1 | 1 | D | E | EUGENE C |  | 11-026 |  | 12-054F | 17.5 | 82.5 | 100 | 100 | 07-024 |  |  |  |  |  |  |  |  |  |  |  |  |  |  |  |  |  |  |  |
| 15231030 |  | Proc Magnetic Shield Boxes (TOF) | 80d | 2013-07-01 A | 2013-08-30 A | 9-130M FS+165d, 15231001a, 12323040M | 100% |  | 2013-08-01 | 2013-11-21 |  |  |  | PROCUREMENT>$50K 69 | 11,358.55 |  | 0 | 11358.55 | 1135855 | 100 | 11358.55 | 11358.55 | CHUDAKOV | 1 | 1 | D | D | EUGENE C |  | 11-026 | 12-021 |  |  |  |  |  |  |  |  | 09-027 | 09-027 | 11-006 |  |  |  |  |  |  |  |  |  |  |  |  |  |  |
| 15231045 |  | Proc Supprt Struct (TOF) | 40d | 2013-07-01 A | 2013-08-30 A | 9-130M FS+165d, 12323040M, 15231001a | 100% |  | 2013-08-01 | 2013-09-26 |  |  |  | PROCUREMENT<$50K 60 | 24,146.57 |  | 0 | 24146.57 | 2414657 | 100 | 24146.57 | 24146.57 | CHUDAKOV | 1 | 1 | D | D | EUGENE C |  | 11-026 | 12-021F |  |  |  |  |  |  |  |  | 09-027 | 09-027 | 11-006 |  |  |  |  |  |  |  |  |  |  |  |  |  |  |
| 15231150 |  | Re-Baseline Actuals Adjustment | 1d | 2013-08-30 A | 2013-08-30 A |  | 100% |  | 2013-09-03 | 2013-09-03 |  |  |  | PROCUREMENT>$50K 69 NO ESCALATION | -66,828.86 |  |  |  |  | 100 |  |  |  |  |  |  |  |  |  |  |  |  |  |  |  |  |  |  |  |  |  |  |  |  |  |  | ADJ |  |  |  |  |  |  |  |  |  |
| 25231010 |  | FSU contract support and supervision FY13 | 57d | 2013-09-03 A | 2013-09-30 A | 9-130M FS+228d | 100% |  | 2013-10-01 | 2013-12-20 |  |  | 8/5 M-F w/JLAB Holidays ReBaseline | SCIENTIST [35.4 h]; MECH DES [8.6 h]; MECH ENG [4.3 h] | 3,424.29 | 3,318.53 |  |  |  |  |  | 0 | CHUDAKOV | 1 | 1 | D | E | EUGENE C |  | 11-026 | 12-021 |  | 64.9122807 | 35.08771929 | 100 | 100 |  |  |  |  |  |  |  |  | 12-049 |  |  | 25231010 | 3318.539083 | 13-007 | PE | 13-015 | PR |  |  |  |
| 25231030 |  | Proc Magnetic Shields (TOF) | 34d | 2013-09-03 A | 2013-10-21 A | 9-140M | 100% |  | 2013-11-01 | 2013-12-20 |  |  | 8/5 M-F w/JLAB Holidays ReBaseline | PROCUREMENT>$50K 69 | 5,860.44 |  | 0 | 5860.44 | 586044 | 100 |  | 4102.308 | CHUDAKOV | 1 | 1 | D | D | EUGENE C |  | 11-026 | 12-021 |  |  |  |  |  |  |  |  | 09-027 | 09-027 | 11-006 |  |  |  |  |  | 25231030 | 1758.132 | 13-007 |  | 13-015 | PR | PE | OB-2 | 14-001 |
| 25231085 |  | FSU - Initial wrapping and fitup | 20d | 2013-09-03 A | 2013-09-23 A | 9-130M FS+228d | 100% |  | 2013-10-01 | 2013-10-28 |  |  | 8/5 M-F w/JLAB Holidays ReBaseline | PROCUREMENT>$50K 69 NO ESCALATION | 179,568.62 |  | 0 | 179568.62 | 17956862 | 100 |  | 0 | CHUDAKOV | 1 | 1 | D | D | EUGENE C |  | 11-026 | 12-021 |  |  |  |  |  |  |  |  |  |  | 11-006 |  |  | 12-049 |  |  | 25231090 | 179568.62 | 13-007F |  | 13-015 | PR | OB | OB |  |
| 25231090 |  | FSU - Proc Supplies (TOF) | 20d | 2013-09-03 A | 2013-12-02 | 9-130M FS+228d | 60% | 20d | 2013-10-01 | 2013-10-28 | 68d | 0d | 8/5 M-F w/JLAB Holidays ReBaseline | PROCUREMENT>$50K 69 NO ESCALATION | 2,363.35 |  | 945.34 | 1418.01 | 141801 | 100 |  | 0 | CHUDAKOV | 1 | 1 | D | D | EUGENE C |  | 11-026 | 12-021 |  |  |  |  |  |  |  |  |  |  | 11-006 |  |  | 12-049 |  |  | 25231090 | 1418.01 | 13-007F |  | 13-015 | PR | OB | OB |  |
| 25231105 |  | FSU - Mount PMT and Testing of First 30 Units | 20d | 2013-09-03 A | 2013-09-23 A | 9-130M FS+228d | 100% |  | 2013-10-01 | 2013-10-28 |  |  | 8/5 M-F w/JLAB Holidays ReBaseline | PROCUREMENT>$50K 69 NO ESCALATION | 7,683.34 |  | 0 | 7683.34 | 768334 | 100 |  | 0 | CHUDAKOV | 1 | 1 | D | D | EUGENE C |  |  |  |  |  |  |  |  |  |  |  |  |  |  |  |  | 12-049 |  |  | 25231105 | 7683.34 | 13-007F |  | 13-015 | PR | OB | OB |  |
| 25231115 |  | FSU - Wrapping of Second 30 Units | 20d | 2013-09-03 A | 2013-09-23 A | 25231105 FS-20d | 100% |  | 2013-10-01 | 2013-10-28 |  |  | 8/5 M-F w/JLAB Holidays ReBaseline | PROCUREMENT>$50K 69 NO ESCALATION | 450.73 |  | 0 | 450.73 | 45073 | 100 |  | 0 | CHUDAKOV | 1 | 1 | D | D | EUGENE C |  |  |  |  |  |  |  |  |  |  |  |  |  |  |  |  | 12-049 |  |  | 25231115 | 450.73 | 13-007F |  | 13-015 | PR | OB | OB |  |
| 25231120 |  | FSU - Mount PMT and Testing of Second 30 Units | 20d | 2013-09-03 A | 2013-09-23 A | 25231115 FS-20d | 100% |  | 2013-10-01 | 2013-10-28 |  |  | 8/5 M-F w/JLAB Holidays ReBaseline | PROCUREMENT>$50K 69 NO ESCALATION | 9,369.93 |  | 0 | 9369.93 | 936993 | 100 |  | 0 | CHUDAKOV | 1 | 1 | D | D | EUGENE C |  |  |  |  |  |  |  |  |  |  |  |  |  |  |  |  | 12-049 |  |  | 25231120 | 9369.93 | 13-007F |  | 13-015 | PR | OB | OB |  |
| 25231125 |  | FSU - Polishing and Gluing of Third 30 Units | 43d | 2013-09-03 A | 2013-09-23 A | 25231120 FS-20d | 100% |  | 2013-10-01 | 2013-12-02 |  |  | 8/5 M-F w/JLAB Holidays ReBaseline | PROCUREMENT>$50K 69 NO ESCALATION | 1,146.8 |  | 0 | 1146.8 | 114680 | 100 |  | 0 | CHUDAKOV | 1 | 1 | D | D | EUGENE C |  |  |  |  |  |  |  |  |  |  |  |  |  |  |  |  | 12-049 |  |  | 25231125 | 1146.8 | 13-007F |  | 13-015 | PR | OB | OB |  |
| 25231130 |  | FSU - Wrapping of Third 30 Units | 43d | 2013-09-03 A | 2013-12-05 | 25231125 FS-43d | 70% | 23d | 2013-10-01 | 2013-12-02 | 132d | 20d | 8/5 M-F w/JLAB Holidays ReBaseline | PROCUREMENT>$50K 69 NO ESCALATION | 9,014.5 |  | 2704.35 | 6310.15 | 631015 | 100 |  | 0 | CHUDAKOV | 1 | 1 | D | D | EUGENE C |  |  |  |  |  |  |  |  |  |  |  |  |  |  |  |  | 12-049 |  |  | 25231130 | 6310.15 | 13-007F |  | 13-015 | PR | OB | OB |  |
| 25231135 |  | FSU - Mount PMT and Testing of Third 30 Units | 43d | 2013-09-03 A | 2013-09-23 A | 25231130 FS-43d | 100% |  | 2013-10-01 | 2013-12-02 |  |  | 8/5 M-F w/JLAB Holidays ReBaseline | PROCUREMENT>$50K 69 NO ESCALATION | 14,054.9 |  | 0 | 14054.9 | 1405490 | 100 |  | 0 | CHUDAKOV | 1 | 1 | D | D | EUGENE C |  |  |  |  |  |  |  |  |  |  |  |  |  |  |  |  | 12-049 |  |  | 25231135 | 14054.9 | 13-007F |  | 13-015 | PR | OB | OB |  |
| 25231140 |  | FSU - Construction Manager | 62d | 2013-09-03 A | 2013-11-27 | 25231135 FS-43d | 69% | 19d | 2013-10-01 | 2014-01-08 | 112d | 43d | 8/5 M-F w/JLAB Holidays ReBaseline | PROCUREMENT>$50K 69 NO ESCALATION | 21,380.59 |  | 6553.150835 | 14827.439165 | 1482743.9165 | 100 |  | 7930.060831 | CHUDAKOV | 1 | 1 | D | E | EUGENE C |  |  |  |  | 30.64516129 | 69.3548387 | 100 | 100 |  |  |  |  |  |  |  |  | 12-049 |  |  | 25231140 | 6897.378334 | 13-007F |  | 13-015 | PR | OB | OB |  |
| 25231145 |  | FSU - Shipping of TOF | 77d | 2013-09-03 A | 2013-12-20 | 25231140 FS-62d |  | 34d | 2013-10-01 | 2014-01-30 | 69d | 1d | 8/5 M-F w/JLAB Holidays ReBaseline | PROCUREMENT>$50K 69 NO ESCALATION | 11,939.51 |  | 11939.51 | 0 | 0 | 100 |  | 0 | CHUDAKOV | 1 | 1 | D | D | EUGENE C |  |  |  |  |  |  |  |  |  |  |  |  |  |  |  |  | 12-049 |  |  | 25231145 |  | 13-007F |  | 13-015 | PR | OB | OB |  |
| 25231010a |  | FSU contract support and supervision FY14 | 37d | 2013-10-01 A | 2013-11-27 | 25231010 | 49% | 19d | 2013-11-01 | 2014-01-06 | 269d | 201d | 8/5 M-F w/JLAB Holidays ReBaseline | SCIENTIST [65.5 h]; MECH DES [15.92 h]; MECH ENG [7.96 h] | 6,334.7 | 3,468.99 |  |  |  |  |  | 3081.82999125 | CHUDAKOV | 1 | 1 | D | E | EUGENE C |  | 11-026 | 12-021 |  | 51.35135135 | 48.64864864 | 100 | 100 |  |  |  |  |  |  |  |  | 12-049 |  |  | 25231010 |  | 13-007 | PE | 13-015 | PR |  |  | 14-001 |
| 25231045 |  | Proc Supprt Struct (TOF) | 47d | 2013-10-21 A | 2014-01-31 | 9-140M | 8% | 55d | 2013-12-18 | 2014-03-05 | 63d | 0d | 8/5 M-F w/JLAB Holidays ReBaseline | PROCUREMENT<$50K 60 | 22,425.16 |  | 20631.1472 | 1794.0128 | 179401.28 | 100 |  | 1794.0128 | CHUDAKOV | 1 | 1 | D | D | EUGENE C |  | 11-026 | 12-021F |  |  |  |  |  |  |  |  | 09-027 | 09-027 | 11-006 |  |  |  |  |  | 25231045 |  | 13-007 |  | 13-015 | PR | PE | OB-2 | 14-001 |

| ID | WBS | Activity | Duration | Start | Finish | Predecessors | Complete | Planned start | Planned finish | Resources | Cost | Actual cost | LOE % Pre Calc | LOE % | LOE Divider | LOE Multiplier | Calculated Remaining Total Cost | MONTHLY EV COST | RESP - Responsibility | STRT%COMP for CM EVM | FNSH%COMP for CM EVM | HALL D Related Milestones | CR 07-024 | EVMS Reporting Codes | CAM RESPONSIBLE | CR 11-026 | CR 07-027 | Profile change | Advance Purchase Plan > 500K | CR 08-016 | 12 GEV MAJOR PROCUREMENT CATAGORY | CR 09-012 | CR 11-006 | CR 12-021 | CR 12-054 | CR 10-042 | Remaining Material Cost Based on % Compl | Claimed Material Cost Based on % Complet | Initial Claimed Material Calc | Claimed Material Divider | CR 12-001 | CR 12-053 | CR 12-055 | MARCH!!! | CR 08-052 |
| --- | --- | --- | --- | --- | --- | --- | --- | --- | --- | --- | --- | --- | --- | --- | --- | --- | --- | --- | --- | --- | --- | --- | --- | --- | --- | --- | --- | --- | --- | --- | --- | --- | --- | --- | --- | --- | --- | --- | --- | --- | --- | --- | --- | --- | --- |
|  | 2 | **1.5.2.3.2 CERENKOV COUNTER** |  |  |  |  |  |  |  |  |  |  |  |  |  |  |  |  |  |  |  |  |  |  |  |  |  |  |  |  |  |  |  |  |  |  |  |  |  |  |  |  |  |  |  |
|  | 3 | **1.5.3 COMPUTING** |  | 2010-10-01 | 2014-09-30 |  |  |  |  |  |  |  |  |  |  |  |  |  |  |  |  |  |  |  |  |  |  |  |  |  |  |  |  |  |  |  |  |  |  |  |  |  |  |  |  |
|  | 1 | **1.5.3.1 DAQ** |  | 2010-10-01 | 2014-09-30 |  |  |  |  |  |  |  |  |  |  |  |  |  |  |  |  |  |  |  |  |  |  |  |  |  |  |  |  |  |  |  |  |  |  |  |  |  |  |  |  |
| 15311011E |  | FY11 Travel (DAQ) | 248d | 2010-10-01 A | 2011-09-30 A | 9-110M | 100% |  |  | TRAVEL | 883.25 |  | 8.46774193 | 91.53225806 | 100 | 100 | 0 | 883.25 | CHUDAKOV | 1 | 1 | D | 07-024 | E | EUGENE C | 11-026 |  |  |  |  |  |  |  |  |  |  |  |  |  |  |  |  |  |  |  |
| 1531005 |  | Proc Single Board Computing PR (DAQ) | 19d | 2011-03-01 A | 2011-03-25 A | 1233040M, 9-110M FS+120d | 100% |  |  | SCIENTIST [40 h] | 2,737.2 | 2,737.2 |  |  |  |  | 0 | 2737.2 | CHUDAKOV | 1 | 1 | D | 07-024 | H | EUGENE C | 11-026 | 07-027 | C | APP | 08-016 | 531 | 09-012 | 11-006 | 12-021F | 12-054F |  |  |  |  |  |  |  |  |  |  |
| 1531180 |  | Proc embedded computers for controls PR | 19d | 2011-03-01 A | 2011-03-25 A | 9-110M FS+120d | 100% |  |  | SCIENTIST [40 h] | 2,737.2 | 2,737.2 |  |  |  |  | 0 | 2737.2 | CHUDAKOV | 1 | 1 | D |  | H | EUGENE C | 11-026 |  |  |  |  |  |  | 11-006 | 12-021F |  | 10-042 |  |  |  |  |  |  |  |  |  |
| 1531200 |  | Proc PLC comm Modules PR | 10d | 2011-03-01 A | 2011-03-14 A | 9-110M FS+78d | 100% |  |  | SCIENTIST [40 h] | 2,737.2 | 2,737.2 |  |  |  |  | 0 | 2737.2 | CHUDAKOV | 1 | 1 | D |  | H | EUGENE C | 11-026 |  |  |  |  |  |  | 11-006 | 12-021F |  | 10-042 |  |  |  |  |  |  |  |  |  |
| 1531230 |  | Proc PLC Controller PR | 10d | 2011-03-01 A | 2011-03-14 A | 9-110M FS+78d | 100% |  |  | SCIENTIST [40 h] | 2,737.2 | 2,737.2 |  |  |  |  | 0 | 2737.2 | CHUDAKOV | 1 | 1 | D |  | H | EUGENE C | 11-026 |  |  |  |  |  |  | 11-006 | 12-021 |  | 10-042 |  |  |  |  |  |  |  |  |  |
| 1531205 |  | Proc PLC comm Modules | 9d | 2011-03-15 A | 2011-03-25 A | 1531200 | 100% |  |  | PROCUREMENT<$50K 60 | 4,000 |  |  |  |  |  | 0 | 4000 | CHUDAKOV | 1 | 1 | D |  | D | EUGENE C | 11-026 |  |  |  |  |  |  | 11-006 | 12-021F |  | 10-042 | 0 | 4000 | 400000 | 100 |  |  |  |  |  |
| 1531235 |  | Proc PLC Controller | 9d | 2011-03-15 A | 2011-03-25 A | 1531230 | 100% |  |  | PROCUREMENT<$50K 60 | 6,000 |  |  |  |  |  | 0 | 6000 | CHUDAKOV | 1 | 1 | D |  | D | EUGENE C | 11-026 |  |  |  |  |  |  | 11-006 |  |  | 10-042 | 0 | 6000 | 600000 | 100 |  |  |  |  |  |
| 1531005a |  | Proc Single Board Computing First items (DAQ) | 61d | 2011-03-25 A | 2011-06-20 A | 1531005 | 100% |  |  | PROCUREMENT<$50K 60 | 20,000 |  |  |  |  |  | 0 | 20000 | CHUDAKOV | 1 | 1 | D |  | D | EUGENE C | 11-026 |  |  | APP |  | 531 |  | 11-006 | 12-021F | 12-054F |  | 0 | 20000 | 2000000 | 100 |  |  |  |  |  |
| 1531185 |  | Proc embedded computers for controls | 112d | 2011-03-25 A | 2011-08-31 A | 1531180 | 100% |  |  | PROCUREMENT<$50K 60 | 1,000 |  |  |  |  |  | 0 | 1000 | CHUDAKOV | 1 | 1 | D |  | D | EUGENE C | 11-026 |  |  |  |  |  |  | 11-006 | 12-021F |  | 10-042 | 0 | 1000 | 100000 | 100 |  |  |  |  |  |
| 1531170 |  | Software Licenses and Fees FY11 | 106d | 2011-04-02 A | 2011-08-31 A | 9-110M FS+59d | 100% | 2011-04-04 | 2011-08-31 | PROCUREMENT<$50K 60 | 8,000 |  |  |  |  |  | 0 | 8000 | CHUDAKOV | 1 | 1 | D |  | D | EUGENE C | 11-026 |  |  |  |  |  |  | 11-006 | 12-021F |  | 10-042 | 0 | 8000 | 800000 | 100 |  |  |  |  |  |
| 1531005b |  | Proc Single Board Computing Test First items (DAQ) FY11 | 38d | 2011-06-01 A | 2011-07-25 A | 1531005a | 100% |  |  | SCIENTIST [27.35 h] | 1,871.56 | 1,871.56 |  |  |  |  | 0 | 1871.5605 | CHUDAKOV | 1 | 1 | D |  | H | EUGENE C | 11-026 |  |  | APP |  | 531 |  | 11-006 | 12-021F | 12-054F |  |  |  |  |  | 12-001 |  |  |  |  |
| 1531005ba |  | Proc Single Board Computing Test First items (DAQ) FY12 | 38d | 2011-06-01 A | 2011-07-25 A | 1531005b | 100% |  |  | SCIENTIST [132.65 h] | 9,077.24 | 9,077.24 |  |  |  |  | 0 | 9366.4165 | CHUDAKOV | 1 | 1 | D |  | H | EUGENE C | 11-026 |  |  | APP |  | 531 |  | 11-006 | 12-021F | 12-054F |  |  |  |  |  | 12-001 |  |  |  |  |
| 1531240 |  | Install PLC Controller | 11d | 2011-07-11 A | 2011-07-25 A | 1531235 FS+100d | 100% |  |  | SCIENTIST [40 h] | 2,737.2 | 2,737.2 |  |  |  |  | 0 | 2737.2 | CHUDAKOV | 1 | 1 | D |  | H | EUGENE C | 11-026 |  |  |  |  |  |  | 11-006 |  |  | 10-042 |  |  |  |  |  |  |  |  |  |
| 1531055 |  | Proc UPS (DAQ) PR | 23d | 2011-08-01 A | 2011-08-31 A | 9-120M | 100% |  |  | SCIENTIST [80 h]; COMP SCIENT [40 h] | 8,018 | 8,018 |  |  |  |  | 0 | 8273.6 | CHUDAKOV | 1 | 1 | D |  | H | EUGENE C | 11-026 |  |  | APP |  | 531 |  | 11-006 | 12-021F | 12-054F |  |  |  |  |  |  |  |  |  |  |
| 1531080 |  | Proc Racks (DAQ) PR | 10d | 2011-09-05 A | 2011-09-19 A | 9-110M FS+204d | 100% | 2011-09-06 | 2011-09-19 | SCIENTIST [40 h] | 2,737.2 | 2,737.2 |  |  |  |  | 0 | 2737.2 | CHUDAKOV | 1 | 1 | D | 07-024 | H | EUGENE C | 11-026 | 07-027 |  | APP |  | 531 |  | 11-006 | 12-021F | 12-054F |  |  |  |  |  |  |  |  |  |  |
| 1531010 |  | Proc Large Network Switch (DAQ) PR | 11d | 2011-10-03 A | 2011-10-17 A | 9-120M FS+163d | 100% |  |  | COMP SCIENT [40 h] | 2,624.8 | 2,624.8 |  |  |  |  | 0 | 2624.8 | CHUDAKOV | 1 | 1 | D |  | H | EUGENE C | 11-026 |  |  | APP |  | 531 |  | 11-006 | 12-021F | 12-054F |  |  |  |  |  |  |  |  |  |  |
| 1531015 |  | Proc Small Network Switch (DAQ) PR | 11d | 2011-10-03 A | 2011-10-17 A | 9-120M FS+58d | 100% |  |  | COMP SCIENT [40 h] | 2,624.8 | 2,624.8 |  |  |  |  | 0 | 2624.8 | CHUDAKOV | 1 | 1 | D |  | H | EUGENE C | 11-026 |  |  | APP |  | 531 |  | 11-006 | 12-021F | 12-054F |  |  |  |  |  |  |  |  |  |  |
| 1531057 |  | Proc UPS (DAQ) | 67d | 2011-10-03 A | 2012-01-16 A | 1531055 | 100% | 2011-10-03 | 2012-01-13 | PROCUREMENT<$50K 60 NO ESCALATION FY13; PROCUREMENT>$50K 69 NO ESCALATION FY13 | 78,424.4 |  |  |  |  |  | 0 | 78424.4 | CHUDAKOV | 1 | 1 | D |  | D | EUGENE C | 11-026 |  |  | APP |  | 531 |  | 11-006 | 12-021F | 12-054F |  | 0 | 78424.4 | 7842440 | 100 |  |  |  |  |  |
| 1531082 |  | Proc Racks (DAQ) | 36d | 2011-10-03 A | 2011-11-21 A | 1531080 | 100% |  |  | PROCUREMENT<$50K 60 | 26,829.4 |  |  |  |  |  | 0 | 26829.4 | CHUDAKOV | 1 | 1 | D | 07-024 | D | EUGENE C | 11-026 | 07-027 |  | APP |  | 531 |  | 11-006 | 12-021F | 12-054F |  | 0 | 26829.4 | 2682940 | 100 |  |  |  |  |  |
| 15311012E |  | FY12 Travel (DAQ) | 247d | 2011-10-03 A | 2012-09-28 A | 15311011E | 100% |  |  | TRAVEL | 1,547.85 |  | 7.69230769 | 92.3076923 | 100 | 100 | 0 | 1547.85 | CHUDAKOV | 1 | 1 | D | 07-024 | E | EUGENE C | 11-026 |  |  |  |  |  |  | 11-006 |  |  |  |  |  |  |  |  |  |  |  |  |
| 1531145 |  | Proc Net Switches for Controls PR FY12 | 11d | 2011-10-03 A | 2011-10-17 A | 9-130M | 100% |  |  | SCIENTIST [26.8 h] | 1,892.35 | 1,892.35 |  |  |  |  | 0 | 1892.348 | CHUDAKOV | 1 | 1 | D |  | H | EUGENE C | 11-026 |  |  |  |  |  |  | 11-006 |  |  | 10-042 |  |  |  |  |  | 12-053 |  |  |  |
| 1531145a |  | Proc Net Switches for Controls PR FY13 | 11d | 2011-10-03 A | 2011-10-17 A | 1531145 | 100% |  |  | SCIENTIST [13.2 h] | 932.05 | 932.05 |  |  |  |  | 0 | 961.752 | CHUDAKOV | 1 | 1 | D |  | H | EUGENE C | 11-026 |  |  |  |  |  |  | 11-006 |  |  | 10-042 |  |  |  |  |  | 12-053 |  |  |  |
| 1531175 |  | Software Licenses and Fees FY12 | 247d | 2011-10-03 A | 2012-09-28 A | 9-120M, 1531170 | 100% |  |  | PROCUREMENT<$50K 60 | 4,127.6 |  | 6.55737704 | 93.44262295 | 100 | 100 | 0 | 4127.6 | CHUDAKOV | 1 | 1 | D |  | E | EUGENE C | 11-026 |  |  |  |  |  |  | 11-006 | 12-021F |  | 10-042 | 0 | 4127.6 | 412760 | 100 |  |  |  |  |  |
| 1531210 |  | Proc PLC Point I/O Chassis PR | 36d | 2011-10-03 A | 2011-11-21 A | 9-120M | 100% |  |  | SCIENTIST [40 h] | 2,824.4 | 2,824.4 |  |  |  |  | 0 | 2824.4 | CHUDAKOV | 1 | 1 | D |  | H | EUGENE C | 11-026 |  |  |  |  |  |  | 11-006 | 12-021F |  | 10-042 |  |  |  |  |  |  |  |  |  |
| 1531017 |  | Proc Small Network Switch (DAQ) Phase 1 | 15d | 2011-11-01 A | 2011-11-21 A | 1531015 FS+40d | 100% |  |  | PROCUREMENT<$50K 60 | 25,797.5 |  |  |  |  |  | 0 | 25797.5 | CHUDAKOV | 1 | 1 | D |  | D | EUGENE C | 11-026 |  |  | APP |  | 531 |  | 11-006 | 12-021F | 12-054F |  | 0 | 25797.5 | 2579750 | 100 |  |  |  |  |  |
| 1531018 |  | Proc Small Network Switch (DAQ) Phase 2 | 15d | 2011-11-01 A | 2011-11-21 A | 1531017 | 100% |  |  | PROCUREMENT<$50K 60 NO ESCALATION FY13 | 25,797.5 |  |  |  |  |  | 0 | 25797.5 | CHUDAKOV | 1 | 1 | D |  | D | EUGENE C | 11-026 |  |  | APP |  | 531 |  | 11-006 | 12-021F | 12-054F |  | 0 | 25797.5 | 2579750 | 100 |  |  |  |  |  |
| 1531150 |  | Proc Net Switches for Controls | 15d | 2011-11-01 A | 2011-11-21 A | 1531145a, 1531145 | 100% |  |  | PROCUREMENT<$50K 60 | 12,777.81 |  |  |  |  |  | 0 | 12777.81 | CHUDAKOV | 1 | 1 | D |  | D | EUGENE C | 11-026 |  |  |  |  |  |  | 11-006 |  |  | 10-042 | 0 | 12777.81 | 1277781 | 100 |  |  |  |  |  |
| 1531012 |  | Proc Large Network Switch (DAQ) | 13d | 2011-11-07 A | 2011-11-23 A | 1531010 FS+40d | 100% |  |  | PROCUREMENT<$50K 60 NO ESCALATION FY13; PROCUREMENT>$50K 69 NO ESCALATION FY13 | 67,073.5 |  |  |  |  |  | 0 | 67073.5 | CHUDAKOV | 1 | 1 | D |  | D | EUGENE C | 11-026 |  |  | APP |  | 531 |  | 11-006 | 12-021F | 12-054F |  | 0 | 67073.5 | 6707350 | 100 |  |  |  |  |  |
| 1531215 |  | Proc PLC Point I/O Chassis | 11d | 2011-11-07 A | 2011-11-21 A | 1531210 | 100% |  |  | PROCUREMENT<$50K 60 | 3,095.7 |  |  |  |  |  | 0 | 3095.7 | CHUDAKOV | 1 | 1 | D |  | D | EUGENE C | 11-026 |  |  |  |  |  |  | 11-006 | 12-021F |  | 10-042 | 0 | 3095.7 | 309570 | 100 |  |  |  |  |  |
| 1531030 |  | Proc Online Computers (DAQ) PR | 9d | 2012-01-02 A | 2012-01-16 A | 9-120M FS+120d | 100% | 2012-01-03 | 2012-01-13 | COMP SCIENT [40 h]; SCIENTIST [40 h] | 5,449.2 | 5,449.2 |  |  |  |  | 0 | 5449.2 | CHUDAKOV | 1 | 1 | D | 07-024 | H | EUGENE C | 11-026 | 07-027 |  | APP |  | 531 | 09-012 | 11-006 | 12-021F | 12-054F |  |  |  |  |  |  |  |  |  |  |
| 1531220 |  | Proc PLC Point I/O Modules PR | 107d | 2012-01-09 A | 2012-06-11 A | 1531215, 9-120M | 100% |  |  | SCIENTIST [40 h] | 2,824.4 | 2,824.4 |  |  |  |  | 0 | 2824.4 | CHUDAKOV | 1 | 1 | D |  | H | EUGENE C | 11-026 |  |  |  |  |  |  | 11-006 | 12-021 |  | 10-042 |  |  |  |  |  |  |  |  |  |
| 1531225 |  | Proc PLC Point I/O Modules Phase 1 | 132d | 2012-01-09 A | 2012-07-16 A | 1531220 FS-100d | 100% |  |  | PROCUREMENT<$50K 60 NO ESCALATION FY13 | 20,000 |  |  |  |  |  | 0 | 20000 | CHUDAKOV | 1 | 1 | D |  | D | EUGENE C | 11-026 |  |  |  |  |  |  | 11-006 | 12-021 |  | 10-042 | 0 | 20000 | 2000000 | 100 |  |  |  |  |  |
| 1531005c |  | Proc Single Board Computing Second items (DAQ) Part A | 211d | 2012-01-16 A | 2012-11-12 A | 1531005ba | 100% | 2012-01-17 | 2012-11-12 | PROCUREMENT<$50K 60 | 11,000 |  |  |  |  |  | 0 | 11000 | CHUDAKOV | 1 | 1 | D |  | D | EUGENE C | 11-026 |  |  | APP |  | 531 |  | 11-006 | 12-021 | 12-054F |  | 0 | 11000 | 1100000 | 100 |  |  | 12-055 |  |  |
| 1531155 |  | Proc VME based electronic for Controls/Monitoring PR | 102d | 2012-01-16 A | 2012-06-11 A | 9-120M | 100% | 2012-01-17 | 2012-06-11 | SCIENTIST [80 h] | 5,648.8 | 5,648.8 |  |  |  |  | 0 | 5648.8 | CHUDAKOV | 1 | 1 | D |  | H | EUGENE C | 11-026 |  |  |  |  |  |  | 11-006 | 12-021F |  | 10-042 |  |  |  |  |  |  |  |  |  |
| 1531090 |  | Proc Test Setup Equipmnt (DAQ) PR | 73d | 2012-02-01 A | 2012-05-14 A | 9-120M FS+82d, 1233040M | 100% |  |  | SCIENTIST [80 h] | 5,648.8 | 5,648.8 |  |  |  |  | 0 | 5648.8 | CHUDAKOV | 1 | 1 | D |  | H | EUGENE C | 11-026 |  |  | APP |  | 531 |  | 11-006 | 12-021F |  |  |  |  |  |  |  |  |  |  |  |
| 1531093 |  | Plan Installation in Counting House | 226d | 2012-02-01 A | 2013-01-14 A | 9-120M FS+82d | 100% | 2012-02-01 | 2012-12-20 | SCIENTIST [80 h]; ELEC TECH [80 h] | 9,253.05 | 9,263.21 |  |  |  |  | 0 | 9179.2 | CHUDAKOV | 1 | 1 | D |  | H | EUGENE C | 11-026 |  |  | APP |  | 531 |  | 11-006 | 12-021F |  |  |  |  |  |  |  |  |  | XX |  |
| 1531190 |  | Test embedded computers for controls | 227d | 2012-02-01 A | 2013-01-14 A | 1531185, 1531205, 1531215, 9-120M FS+82d | 100% | 2012-02-01 | 2012-12-21 | SCIENTIST [40 h] | 2,847.4 | 2,850.22 |  |  |  |  | 0 | 2824.4 | CHUDAKOV | 1 | 1 | D |  | H | EUGENE C | 11-026 |  |  |  |  |  |  | 11-006 | 12-021F |  | 10-042 |  |  |  |  |  |  |  | XX |  |
| 1531060 |  | Proc Wireless (DAQ) PR | 12d | 2012-02-02 A | 2012-02-20 A | 9-120M FS+120d | 100% | 2012-02-02 | 2012-02-17 | COMP SCIENT [40 h] | 2,624.8 | 2,624.8 |  |  |  |  | 0 | 2624.8 | CHUDAKOV | 1 | 1 | D |  | H | EUGENE C | 11-026 |  |  | APP |  | 531 |  | 11-006 | 12-021F | 12-054F |  |  |  |  |  |  |  |  |  |  |
| 1531092 |  | Proc Test Setup Equipmnt (DAQ) Part A | 166d | 2012-02-06 A | 2012-09-28 A | 1531090 FS-100d, 9-120M | 100% |  |  | PROCUREMENT<$50K 60 NO ESCALATION FY13 | 40,500 |  |  |  |  |  | 0 | 40500 | CHUDAKOV | 1 | 1 | D |  | D | EUGENE C | 11-026 |  |  | APP |  | 531 |  | 11-006 | 12-021 |  |  | 0 | 40500 | 4050000 | 100 |  |  | 12-055 |  |  |
| 1531062 |  | Proc Wireless (DAQ) | 133d | 2012-02-13 A | 2012-08-20 A | 1531060 | 100% |  |  | PROCUREMENT<$50K 60 | 46,435.5 |  |  |  |  |  | 0 | 46435.5 | CHUDAKOV | 1 | 1 | D |  | D | EUGENE C | 11-026 |  |  | APP |  | 531 |  | 11-006 | 12-021F | 12-054F |  | 0 | 46435.5 | 4643550 | 100 |  |  |  |  |  |
| 1531050 |  | Proc terminal servers (DAQ) PR | 5d | 2012-06-02 A | 2012-06-11 A | 9-120M FS+141d | 100% | 2012-06-05 | 2012-06-11 | COMP SCIENT [40 h] | 2,624.8 | 2,624.8 |  |  |  |  | 0 | 2624.8 | CHUDAKOV | 1 | 1 | D |  | H | EUGENE C | 11-026 |  |  | APP |  | 531 |  | 11-006 | 12-021F | 12-054F |  |  |  |  |  |  |  |  |  |  |
| 1531160 |  | Proc VME based electronic for Controls/Monitoring | 55d | 2012-06-02 A | 2012-08-20 A | 9-120M FS+163d, 1531155 | 100% | 2012-06-05 | 2012-08-20 | PROCUREMENT<$50K 60 | 45,000 |  |  |  |  |  | 0 | 45000 | CHUDAKOV | 1 | 1 | D |  | D | EUGENE C | 11-026 |  |  |  |  |  |  | 11-006 | 12-021 |  | 10-042 | 0 | 45000 | 4500000 | 100 |  |  |  |  |  |
| 1531032 |  | Proc Online Computers (DAQ) Phase 1 Part A | 248d | 2012-07-02 A | 2013-01-14 A | 9-120M FS+205d, 1531030 | 100% | 2012-07-02 | 2013-06-28 | PROCUREMENT<$50K 60 NO ESCALATION FY13 | 12,000 |  |  |  |  |  | 0 | 12000 | CHUDAKOV | 1 | 1 | D | 07-024 | D | EUGENE C | 11-026 | 07-027 |  | APP |  | 531 | 09-012 | 11-006 | 12-021 | 12-054F |  | 0 | 12000 | 1200000 | 100 |  |  | 12-055 |  |  |
| 1531227 |  | Proc PLC Point I/O Modules Phase 2 Part A | 122d | 2012-07-02 A | 2013-03-11 A | 1531225 | 100% | 2012-07-02 | 2012-12-21 | PROCUREMENT<$50K 60 | 17,232.73 |  |  |  |  |  | 0 | 17232.73 | CHUDAKOV | 1 | 1 | D |  | D | EUGENE C | 11-026 |  |  |  |  |  |  | 11-006 | 12-021 |  | 10-042 | 0 | 17232.73 | 1723273 | 100 |  |  | 12-055 | XX |  |
| 1531052 |  | Proc terminal servers (DAQ) | 23d | 2012-07-19 A | 2012-08-20 A | 1531050 | 100% |  |  | PROCUREMENT<$50K 60 NO ESCALATION FY13 | 8,255.2 |  |  |  |  |  | 0 | 8255.2 | CHUDAKOV | 1 | 1 | D |  | D | EUGENE C | 11-026 |  |  | APP |  | 531 |  | 11-006 | 12-021F | 12-054F |  | 0 | 8255.2 | 825520 | 100 |  |  |  |  |  |
| 1531005ca |  | Proc Single Board Computing Second items (DAQ) Part B | 81d | 2012-10-01 A | 2013-02-11 A | 1531005ba | 100% | 2012-10-01 | 2013-02-01 | PROCUREMENT<$50K 60 | 29,000 |  |  |  |  |  | 0 | 29000 | CHUDAKOV | 1 | 1 | D |  | D | EUGENE C | 11-026 |  |  | APP |  | 531 |  | 11-006 | 12-021 | 12-054F |  | 0 | 29000 | 2900000 | 100 |  |  | 12-055 | XX |  |
| 1531048 |  | Proc Fibers Installation from Rack Room to Telecom Room (DAQ) | 16d | 2012-10-01 A | 2012-10-22 A | 9-130M | 100% |  |  | PROCUREMENT<$50K 60 | 10,319 |  |  |  |  |  | 0 | 10319 | CHUDAKOV | 1 | 1 | D |  | D | EUGENE C | 11-026 |  |  | APP |  | 531 |  | 11-006 | 12-021 | 12-054 |  | 0 | 10319 | 1031900 | 100 |  |  |  |  |  |
| 15311013E |  | FY13 Travel (DAQ) | 59d | 2012-10-01 A | 2012-12-31 A | 15311012E | 100% |  |  | TRAVEL | 1,597.23 |  | 27.11864406 | 72.88135593 | 100 | 100 | 0 | 1597.23 | CHUDAKOV | 1 | 1 | D | 07-024 | E | EUGENE C | 11-026 |  |  |  |  |  |  | 11-006 |  |  |  |  |  |  |  |  |  |  |  | 08-052 |
| 1531092a |  | Proc Test Setup Equipmnt (DAQ) Part B | 11d | 2012-11-03 A | 2012-11-19 A | 9-120M, 1531090 FS-100d | 100% | 2012-11-05 | 2012-11-19 | PROCUREMENT<$50K 60 NO ESCALATION FY13 | 4,500 |  |  |  |  |  | 0 | 4500 | CHUDAKOV | 1 | 1 | D |  | D | EUGENE C | 11-026 |  |  | APP |  | 531 |  | 11-006 | 12-021 |  |  | 0 | 4500 | 450000 | 100 |  |  | 12-055 |  |  |
| 1531045 |  | Proc Telecom Installation (DAQ) PR | 21d | 2013-01-02 A | 2013-01-30 A | 9-120M FS+185d, 9-130M FS+70d | 100% | 2013-02-01 | 2013-03-04 | SCIENTIST [40 h] | 2,914.4 | 2,914.4 |  |  |  |  | 0 | 2824.4 | CHUDAKOV | 1 | 1 | D |  | H | EUGENE C | 11-026 |  |  | APP |  | 531 |  | 11-006 | 12-021 | 12-054F |  |  |  |  |  |  |  |  | XX |  |
| 1531020 |  | Proc EB nodes (DAQ) PR | 21d | 2013-01-07 A | 2013-01-21 A | 9-130M FS+70d, 9-120M FS+200d | 100% | 2013-02-01 | 2013-03-04 | SCIENTIST [40 h]; COMP SCIENT [40 h] | 5,622.8 | 5,622.8 |  |  |  |  | 0 | 5449.2 | CHUDAKOV | 1 | 1 | D |  | H | EUGENE C | 11-026 |  |  | APP |  | 531 |  | 11-006 | 12-021F | 12-054F |  |  |  |  |  |  |  |  | XX |  |
| 1531025 |  | Proc RAID disks (DAQ) PR | 40d | 2013-01-07 A | 2013-01-21 A | 9-130M FS+60d | 100% | 2013-02-01 | 2013-03-29 | SCIENTIST [40 h]; COMP SCIENT [40 h] | 5,622.8 | 5,622.8 |  |  |  |  | 0 | 5622.8 | CHUDAKOV | 1 | 1 | D | 07-024 | H | EUGENE C | 11-026 | 07-027 |  | APP |  | 531 | 09-012 | 11-006 | 12-021 |  |  |  |  |  |  |  |  |  |  |  |
| 1531040 |  | Proc file servers (DAQ) PR | 30d | 2013-01-07 A | 2013-01-21 A | 9-130M FS+70d | 100% | 2013-02-01 | 2013-03-15 | SCIENTIST [40 h]; COMP SCIENT [40 h] | 5,622.8 | 5,622.8 |  |  |  |  | 0 | 5622.8 | CHUDAKOV | 1 | 1 | D | 07-024 | H | EUGENE C | 11-026 | 07-027 |  | APP |  | 531 |  | 11-006 | 12-021 | 12-054F |  |  |  |  |  |  |  |  |  |  |
| 1531075 |  | Proc Consoles (DAQ) PR | 23d | 2013-01-07 A | 2013-02-11 A | 9-130M FS+43d, 9-120M FS+82d | 100% | 2013-02-01 | 2013-03-06 | SCIENTIST [40 h] | 2,914.4 | 2,914.4 |  |  |  |  | 0 | 2824.4 | CHUDAKOV | 1 | 1 | D | 07-024 | H | EUGENE C | 11-026 | 07-027 |  | APP |  | 531 |  | 11-006 | 12-021F | 12-054F |  |  |  |  |  |  |  |  | XX |  |
| 1531085 |  | Proc funiture (DAQ) PR | 23d | 2013-01-28 A | 2013-03-11 A | 9-120M FS+82d, 9-130M FS+43d | 100% | 2013-02-01 | 2013-03-06 | SCIENTIST [80 h] | 5,828.8 | 5,828.8 |  |  |  |  | 0 | 5648.8 | CHUDAKOV | 1 | 1 | D |  | H | EUGENE C | 11-026 |  |  | APP |  | 531 |  | 11-006 | 12-021F | 12-054F |  |  |  |  |  |  |  |  | XX |  |
| 1531042 |  | Proc file servers (DAQ) | 65d | 2013-01-29 A | 2013-02-11 A | 1531040 | 100% | 2013-03-20 | 2013-06-19 | PROCUREMENT<$50K 60 | 36,116.5 |  |  |  |  |  | 0 | 36116.5 | CHUDAKOV | 1 | 1 | D | 07-024 | D | EUGENE C | 11-026 | 07-027 |  | APP |  | 531 |  | 11-006 | 12-021 | 12-054F |  | 0 | 36116.5 | 3611650 | 100 |  |  |  |  |  |
| 1531035 |  | Proc large displays (DAQ) PR | 44d | 2013-03-04 A | 2013-03-25 A | 9-130M FS+184d | 100% | 2013-07-01 | 2013-08-30 | COMP SCIENT [40 h] | 2,708.4 | 2,708.4 |  |  |  |  | 0 | 2708.4 | CHUDAKOV | 1 | 1 | D |  | H | EUGENE C | 11-026 |  |  | APP |  | 531 |  | 11-006 | 12-021 |  |  |  |  |  |  |  |  |  |  |  |
| 1531077 |  | Proc Consoles (DAQ) | 45d | 2013-03-04 A | 2013-08-30 A | 1531075, 9-130M FS+55d | 100% | 2013-04-10 | 2013-06-12 | PROCUREMENT<$50K 60 | 41,276 |  |  |  |  |  | 8255.2 | 41276 | CHUDAKOV | 1 | 1 | D | 07-024 | D | EUGENE C | 11-026 | 07-027 |  | APP |  | 531 |  | 11-006 | 12-021 | 12-054F |  | 0 | 41276 | 4127600 | 100 |  |  |  |  |  |
| 1531087 |  | Proc furniture (DAQ) | 45d | 2013-03-04 A | 2013-06-17 A | 9-130M FS+43d, 1531085 | 100% | 2013-04-09 | 2013-06-11 | PROCUREMENT<$50K 60; PROCUREMENT>$50K 69 | 51,595 |  |  |  |  |  | 0 | 51595 | CHUDAKOV | 1 | 1 | D |  | D | EUGENE C | 11-026 |  |  | APP |  | 531 |  | 11-006 | 12-021 | 12-054F |  | 0 | 51595 | 5159500 | 100 |  |  |  |  |  |
| 1531037 |  | Proc large displays (DAQ) | 82d | 2013-04-01 A | 2013-04-15 A | 1531035 FS+20d, 9-140M | 100% | 2013-10-01 | 2014-02-04 | PROCUREMENT<$50K 60 | 11,712.99 |  |  |  |  |  | 0 | 0 | CHUDAKOV | 1 | 1 | D |  | D | EUGENE C | 11-026 |  |  | APP |  | 531 |  | 11-006 | 12-021 |  |  | 0 | 11712.99 | 1171299 | 100 |  |  |  |  |  |
| 1531032a |  | Proc Online Computers (DAQ) Phase 1 Part B | 85d | 2013-04-15 A | 2013-05-13 A | 1531030, 9-130M FS+140d, 9-120M FS+205d | 100% | 2013-05-01 | 2013-08-29 | PROCUREMENT<$50K 60 NO ESCALATION FY13 | 23,000 |  |  |  |  |  | 0 | 23000 | CHUDAKOV | 1 | 1 | D | 07-024 | D | EUGENE C | 11-026 | 07-027 |  | APP |  | 531 | 09-012 | 11-006 | 12-021 | 12-054F |  | 0 | 23000 | 2300000 | 100 |  |  | 12-055 |  |  |
| 1531195 |  | Proc remaining embedded computers for controls | 32d | 2013-05-03 A | 2013-05-20 A | 1531190 FS+20d, 9-130M FS+150d | 100% | 2013-06-03 | 2013-07-17 | PROCUREMENT<$50K 60 | 5,159.5 |  |  |  |  |  | 0 | 5159.5 | CHUDAKOV | 1 | 1 | D |  | D | EUGENE C | 11-026 |  |  |  |  |  |  | 11-006 | 12-021 | 12-054 | 10-042 | 0 | 5159.5 | 515950 | 100 |  |  |  |  |  |
| 1531033 |  | Proc Online Computers (DAQ) Phase 2 | 70d | 2013-06-01 A | 2013-06-17 A | 9-130M FS+100d, 1531032 FS-70d, 1531032a FS-70d | 100% | 2013-07-01 | 2013-10-08 | PROCUREMENT<$50K 60 | 59,850.2 |  |  |  |  |  | 0 | 59850.2 | CHUDAKOV | 1 | 1 | D | 07-024 | D | EUGENE C | 11-026 | 07-027 |  | APP |  | 531 | 09-012 | 11-006 | 12-021 |  |  | 0 | 59850.2 | 5985020 | 100 |  |  |  |  |  |
| 1531135 |  | Proc infiniband Switch PR | 42d | 2013-06-01 A | 2013-06-17 A | 9-120M FS+255d, 9-130M FS+135d | 100% | 2013-07-01 | 2013-08-28 | COMP SCIENT [40 h] | 2,708.4 | 2,708.4 |  |  |  |  | 0 | 2624.8 | CHUDAKOV | 1 | 1 | D |  | H | EUGENE C | 11-026 |  |  |  |  |  |  | 11-006 | 12-021 | 12-054F | 10-042 |  |  |  |  |  |  |  |  |  |
| 1531047 |  | Proc Telecom Installation (DAQ) | 32d | 2013-08-01 A | 2013-08-30 A | 1531045 FS+30d | 100% | 2013-08-01 | 2013-09-16 | PROCUREMENT<$50K 60 | 15,478.5 |  |  |  |  |  | 15478.5 | 15478.5 | CHUDAKOV | 1 | 1 | D |  | D | EUGENE C | 11-026 |  |  | APP |  | 531 |  | 11-006 | 12-021 | 12-054 |  | 0 | 15478.5 | 1547850 | 100 |  |  |  |  |  |
| 1531065 |  | Proc Fiber Cables for Counting House to Hall (DAQ) PR | 42d | 2013-08-01 A | 2013-08-26 A | 9-130M FS+120d, 9-120M FS+235d | 100% | 2013-08-01 | 2013-09-30 | SCIENTIST [80 h] | 5,828.8 | 5,828.8 |  |  |  |  | 5648.8 | 5648.8 | CHUDAKOV | 1 | 1 | D |  | H | EUGENE C | 11-026 |  |  | APP |  | 531 |  | 11-006 | 12-021F | 12-054F |  |  |  |  |  |  |  |  |  |  |
| 1531070 |  | Proc Fiber Cables for Counting House to Hall (DAQ) | 21d | 2013-08-01 A | 2013-08-30 A | 1531065, 9-130M FS+40d | 100% | 2013-10-01 | 2013-10-29 | PROCUREMENT<$50K 60 | 25,797.5 |  |  |  |  |  | 25797.5 | 25797.5 | CHUDAKOV | 1 | 1 | D |  | D | EUGENE C | 11-026 |  |  | APP |  | 531 |  | 11-006 | 12-021 | 12-054 |  | 0 | 25797.5 | 2579750 | 100 |  |  |  |  |  |

| ID | Activity | Duration | Start | Finish | Predecessors | Complete | Remaining | Planned start | Planned finish | Total float | Free float | Calendar | Resources | Cost | Actual cost | Remaining Material Cost Based on % Compl | Claimed Material Cost Based on % Complet | Initial Claimed Material Calc | Claimed Material Divider | Calculated Remaining Total Cost | MONTHLY EV COST | RESP - Responsibility | STRT%COMP for CM EVM | FNSH%COMP for CM EVM | HALL D Related Milestones | Advance Purchase Plan > 500K | EVMS Reporting Codes | CAM RESPONSIBLE | 12 GEV MAJOR PROCUREMENT CATAGORY | CR 11-006 | CR 11-026 | CR 12-021 | CR 12-054 | CR 07-024 | CR 07-027 | CR 09-012 | CR 10-042 | CR 12-055 | ReBaseline Actuals Adjustment | Original Activity ID Rebaseline | PRIOR MONTH EV COST | CR 13-007 | BOE Procurement | CR 13-015 | Post Rebaseline | Obligated Prior to Rebaseline | CR 14-001 | LOE Divider | LOE Multiplier | BOE Labor | Activities with Steps | CR 12-040 | LOE % Pre Calc | LOE % |
| --- | --- | --- | --- | --- | --- | --- | --- | --- | --- | --- | --- | --- | --- | --- | --- | --- | --- | --- | --- | --- | --- | --- | --- | --- | --- | --- | --- | --- | --- | --- | --- | --- | --- | --- | --- | --- | --- | --- | --- | --- | --- | --- | --- | --- | --- | --- | --- | --- | --- | --- | --- | --- | --- | --- |
| 1531022 | Proc EB nodes (DAQ) Phase 1 | 63d | 2013-08-30 A | 2013-08-30 A | 1531020 FS+40d, 9-130M FS+145d | 100% |  | 2013-09-03 | 2013-12-02 |  |  |  | PROCUREMENT<$50K 60 | 27,861.3 |  | 0 | 27861.3 | 2786130 | 100 | 27861.3 | 27861.3 | CHUDAKOV | 1 | 1 | D | APP | D | EUGENE C | 531 | 11-006 | 11-026 | 12-021 | 12-054F |  |  |  |  |  |  |  |  |  |  |  |  |  |  |  |  |  |  |  |  |  |
| 1531027 | Proc RAID disks (DAQ) | 84d | 2013-08-30 A | 2013-08-30 A | 1531025 FS+80d | 100% |  | 2013-09-03 | 2014-01-08 |  |  |  | PROCUREMENT>$50K 69; PROCUREMENT<$50K 60 | 56,754.5 |  | 0 | 56754.5 | 5675450 | 100 | 56754.5 | 56754.5 | CHUDAKOV | 1 | 1 | D | APP | D | EUGENE C | 531 | 11-006 | 11-026 | 12-021 |  | 07-024 | 07-027 | 09-012 |  |  |  |  |  |  |  |  |  |  |  |  |  |  |  |  |  |  |
| 1531095 | Install Crates (DAQ) | 62d | 2013-08-30 A | 2013-08-30 A | 1531093, 1562195 FS-20d, 9-130M FS+103d, 1544005d | 100% |  | 2013-09-03 | 2013-11-27 |  |  |  | ELEC TECH [360 h]; SCIENTIST [80 h]; COMP SCIENT [80 h] | 28,236.4 | 27,640 |  |  |  |  | 27640 | 27640 | CHUDAKOV | 1 | 1 | D |  | U | EUGENE C |  | 11-006 | 11-026 | 12-021 | 12-054 |  |  |  | 10-042 |  |  |  |  |  |  |  |  |  |  |  |  |  |  |  |  |  |
| 1531100 | Install Cabling (DAQ) | 64d | 2013-08-30 A | 2013-08-30 A | 1531095, 1531110 FS+8d | 100% |  | 2014-02-19 | 2014-05-19 |  |  |  | COMP SCIENT [200 h]; ELEC TECH [160 h]; SCIENTIST [200 h] | 36,528.4 | 35,400.4 |  |  |  |  | 35400.4 | 35400.4 | CHUDAKOV | 1 | 1 | D |  | U | EUGENE C |  | 11-006 | 11-026 | 12-021 | 12-054 |  |  |  | 10-042 |  |  |  |  |  |  |  |  |  |  |  |  |  |  |  |  |  |
| 1531105 | Install Trigger Electrnc's (DAQ) Phase 1 | 59d | 2013-08-30 A | 2013-08-30 A | 1531092a, 1531092, 1531095 FS-35d, 1532007, 1532005, 1532007a | 100% |  | 2013-10-10 | 2014-01-10 |  |  |  | ELEC TECH [120 h]; SCIENTIST [120 h] | 14,660.4 | 14,208 |  |  |  |  | 14208 | 14208 | CHUDAKOV | 1 | 1 | D |  | H | EUGENE C |  | 11-006 | 11-026 | 12-021 | 12-054 |  |  |  |  |  |  |  |  |  |  |  |  |  |  |  |  |  |  |  |  |  |
| 1531110 | Install DAQ Electrnc's (DAQ) | 41d | 2013-08-30 A | 2013-08-30 A | 1531095, 9-130M FS+59d | 100% |  | 2013-12-02 | 2014-02-05 |  |  |  | ELEC TECH [400 h]; SCIENTIST [400 h] | 48,868 | 47,360 |  |  |  |  | 47360 | 47360 | CHUDAKOV | 1 | 1 | D |  | U | EUGENE C |  | 11-006 | 11-026 | 12-021 | 12-054 |  |  |  | 10-042 |  |  |  |  |  |  |  |  |  |  |  |  |  |  |  |  |  |
| 1531140 | Proc infiniband Switch | 70d | 2013-08-30 A | 2013-08-30 A | 1531135 FS+10d | 100% |  | 2013-09-03 | 2013-12-11 |  |  |  | PROCUREMENT<$50K 60 | 15,478.5 |  | 0 | 15478.5 | 1547850 | 100 | 15478.5 | 15478.5 | CHUDAKOV | 1 | 1 | D |  | D | EUGENE C |  | 11-006 | 11-026 | 12-021 | 12-054F |  |  |  | 10-042 |  |  |  |  |  |  |  |  |  |  |  |  |  |  |  |  |  |
| 1531165 | Install VME based electronic for Controls/Monitoring | 150d | 2013-08-30 A | 2013-08-30 A | 9-130M FS+110d, 1531160 FS+95d | 100% |  | 2013-09-03 | 2014-04-14 |  |  |  | SCIENTIST [240 h] | 17,968.96 | 17,486.4 |  |  |  |  | 17486.4 | 17486.4 | CHUDAKOV | 1 | 1 | D |  | H | EUGENE C |  | 11-006 | 11-026 | 12-021 |  |  |  |  | 10-042 |  |  |  |  |  |  |  |  |  |  |  |  |  |  |  |  |  |
| 1531227a | Proc PLC Point I/O Modules Phase 2 Part B | 64d | 2013-08-30 A | 2013-08-30 A | 1531225, 9-130M FS+160d | 100% |  | 2013-09-03 | 2013-12-03 |  |  |  | PROCUREMENT<$50K 60 | 16,819.97 |  | 0 | 16819.97 | 1681997 | 100 | 16819.97 | 16819.97 | CHUDAKOV | 1 | 1 | D |  | D | EUGENE C |  | 11-006 | 11-026 | 12-021 |  |  |  |  | 10-042 | 12-055 |  |  |  |  |  |  |  |  |  |  |  |  |  |  |  |  |
| 1531245 | Re-Baseline Actuals Adjustment | 1d | 2013-08-30 A | 2013-08-30 A |  | 100% |  | 2013-09-03 | 2013-09-03 |  |  |  | PROCUREMENT>$50K 69 NO ESCALATION | -372,924.07 |  |  |  |  | 100 |  |  |  |  |  |  |  |  |  |  |  |  |  |  |  |  |  |  |  | ADJ |  |  |  |  |  |  |  |  |  |  |  |  |  |  |  |
| 2531005f | Proc Single Board Computing Remaining items (DAQ) | 84d | 2013-09-03 A | 2013-09-23 A | 9-130M FS+228d | 100% |  | 2013-10-01 | 2014-02-10 |  |  | 8/5 M-F w/JLAB Holidays ReBaseline | PROCUREMENT<$50K 60 NO ESCALATION FY14; PROCUREMENT>$50K 69 NO ESCALATION FY14 | 60,911 |  | 0 | 60911 | 6091100 | 100 |  | 0 | CHUDAKOV | 1 | 1 | D | APP | D | EUGENE C | 531 | 11-006 | 11-026 | 12-021 | 12-054F |  |  |  |  |  |  | 2531005f | 60911 | 13-007 | EV | 13-015 | PR | OB |  |  |  |  |  |  |  |  |
| 2531022 | Proc EB nodes (DAQ) | 62d | 2013-09-03 A | 2013-10-21 A | 9-130M FS+228d | 100% |  | 2013-10-01 | 2014-01-08 |  |  | 8/5 M-F w/JLAB Holidays ReBaseline | PROCUREMENT<$50K 60 NO ESCALATION FY14 | 45,500 |  | 0 | 45500 | 4550000 | 100 |  | 45500 | CHUDAKOV | 1 | 1 | D | APP | D | EUGENE C | 531 | 11-006 | 11-026 | 12-021 | 12-054F |  |  |  |  |  |  | 2531022 |  | 13-007 | VQ | 13-015 | PR | OB |  |  |  |  |  |  |  |  |
| 2531027 | Proc RAID disks (DAQ) | 62d | 2013-09-03 A | 2013-10-21 A | 9-130M FS+228d | 100% |  | 2013-10-01 | 2014-01-08 |  |  | 8/5 M-F w/JLAB Holidays ReBaseline | PROCUREMENT<$50K 60 NO ESCALATION FY14 | 25,500 |  | 0 | 25500 | 2550000 | 100 |  | 25500 | CHUDAKOV | 1 | 1 | D | APP | D | EUGENE C | 531 | 11-006 | 11-026 | 12-021 |  | 07-024 | 07-027 | 09-012 |  |  |  | 2531027 |  |  | VQ | 13-015 | PR | OB |  |  |  |  |  |  |  |  |
| 2531077 | Proc Consoles (DAQ) | 20d | 2013-09-03 A | 2013-09-23 A | 9-130M FS+228d | 100% |  | 2013-10-01 | 2013-10-28 |  |  | 8/5 M-F w/JLAB Holidays ReBaseline | PROCUREMENT<$50K 60 | 400 |  | 0 | 400 | 40000 | 100 |  | 0 | CHUDAKOV | 1 | 1 | D | APP | D | EUGENE C | 531 | 11-006 | 11-026 | 12-021 | 12-054F | 07-024 | 07-027 |  |  |  |  | 2531077 | 400 | 13-007 | VQ | 13-015 | PR | OB |  |  |  |  |  |  |  |  |
| 2531140 | Proc infiniband Hardware | 31d | 2013-09-03 A | 2013-10-21 A | 9-130M FS+228d | 100% |  | 2013-10-01 | 2013-11-12 |  |  | 8/5 M-F w/JLAB Holidays ReBaseline | PROCUREMENT<$50K 60 NO ESCALATION FY14 | 13,710 |  | 0 | 13710 | 1371000 | 100 |  | 13710 | CHUDAKOV | 1 | 1 | D |  | D | EUGENE C |  | 11-006 | 11-026 | 12-021 | 12-054F |  |  |  | 10-042 |  |  | 2531140 |  | 13-007 | CP | 13-015 | PR | OB |  |  |  |  |  |  |  |  |
| 2531227aa | Proc IO Modules (DAQ) Batch 2 (Previously Obligated) | 42d | 2013-09-03 A | 2013-09-23 A | 9-130M FS+228d | 100% |  | 2013-10-01 | 2013-11-27 |  |  | 8/5 M-F w/JLAB Holidays ReBaseline | PROCUREMENT<$50K 60 NO ESCALATION FY14 | 4,978.67 |  | 0 | 4978.67 | 497867 | 100 |  | 0 | CHUDAKOV | 1 | 1 | D |  | D | EUGENE C |  | 11-006 | 11-026 | 12-021 |  |  |  |  | 10-042 | 12-055 |  | 2531227aa | 4978.67 | 13-007 | EV | 13-015 | PR | OB |  |  |  |  |  |  |  |  |
| 2531330 | Proc L3 Farm Infrastucture (DAQ) | 30d | 2013-09-03 A | 2013-10-21 A | 9-140M FS-1d | 100% |  | 2013-11-01 | 2013-12-16 |  |  | 8/5 M-F w/JLAB Holidays ReBaseline | PROCUREMENT<$50K 60 NO ESCALATION | 34,101 |  | 0 | 34101 | 3410100 | 100 |  | 34101 | CHUDAKOV | 1 | 1 | D |  | D | EUGENE C |  | 11-006 | 11-026 | 12-021 |  |  |  |  | 10-042 |  |  | 2531330 |  |  | EV | 13-015 | PR | OB |  |  |  |  |  |  |  |  |
| 2531340 | Proc Accessories for Computing Cluster (DAQ) | 82d | 2013-09-03 A | 2014-03-20 | 2531335 FS-25d, 2531335a FS-25d |  | 89d | 2013-11-27 | 2014-04-04 | 95d | 0d | 8/5 M-F w/JLAB Holidays ReBaseline | PROCUREMENT<$50K 60 | 10,348.93 |  | 10348.93 | 0 | 0 | 100 |  | 0 | CHUDAKOV | 1 | 1 | D |  | D | EUGENE C |  | 11-006 | 11-026 | 12-021 |  |  |  |  | 10-042 |  |  | 2531340 |  |  | CP | 13-015 | PR | OB-2 | 14-001 |  |  |  |  |  |  |  |
| 2531350 | Proc Hardware for Microscope Voltage Control (DAQ) | 77d | 2013-09-03 A | 2013-12-20 | 9-130M FS+228d |  | 34d | 2013-10-01 | 2014-01-30 | 128d | 0d | 8/5 M-F w/JLAB Holidays ReBaseline | PROCUREMENT<$50K 60 NO ESCALATION FY14 | 3,000 |  | 3000 | 0 | 0 | 100 |  | 0 | CHUDAKOV | 1 | 1 | D |  | D | EUGENE C |  | 11-006 | 11-026 | 12-021 |  |  |  |  | 10-042 |  |  | 2531350 |  |  | EJ | 13-015 | PR | OB-2 |  |  |  |  |  |  |  |  |
| 2531390 | Installation Coordination | 20d | 2013-09-03 A | 2013-09-30 A | 9-130M FS+228d | 100% |  | 2013-10-01 | 2013-10-28 |  |  | 8/5 M-F w/JLAB Holidays ReBaseline | SCIENTIST [25 h] | 1,879.5 | 1,821.5 |  |  |  |  |  | 0 | CHUDAKOV | 1 | 1 | D |  | E | EUGENE C |  | 11-006 | 11-026 | 12-021 |  |  |  |  | 10-042 |  |  | 2531390 | 1821.5 |  |  | 13-015 | PR |  |  | 100 | 100 | PE |  |  |  |  |
| 2531335 | Proc Accessories for Computing Cluster (DAQ) PR FY13 | 18d | 2013-10-01 A | 2013-10-21 A | 9-140M FS+4d, 9-130M FS+228d | 100% |  | 2013-11-01 | 2013-11-26 |  |  | 8/5 M-F w/JLAB Holidays ReBaseline | SCIENTIST [25.81 h] | 1,940.4 | 1,940.4 |  |  |  |  |  | 1880.5166 | CHUDAKOV | 1 | 1 | D |  | H | EUGENE C |  | 11-006 | 11-026 | 12-021 |  |  |  |  | 10-042 |  |  | 2531335 |  |  |  | 13-015 | PR |  |  |  |  | PE |  |  |  |  |
| 2531335a | Proc Accessories for Computing Cluster (DAQ) PR FY14 | 18d | 2013-10-01 A | 2013-10-21 A | 2531335 FS-18d | 100% |  | 2013-11-01 | 2013-11-26 |  |  | 8/5 M-F w/JLAB Holidays ReBaseline | SCIENTIST [14.19 h] | 1,066.8 | 1,066.8 |  |  |  |  |  | 1066.8042 | CHUDAKOV | 1 | 1 | D |  | H | EUGENE C |  | 11-006 | 11-026 | 12-021 |  |  |  |  | 10-042 |  |  | 2531335 |  |  |  | 13-015 | PR |  | 14-001 |  |  | PE |  |  |  |  |
| 2531375 | Check-out Counting House (DAQ) | 31d | 2013-10-01 A | 2013-12-17 | 9-140M FS+10d, 2531077, 2531390 | 50% | 31d | 2013-11-01 | 2013-12-17 | 193d |  | 8/5 M-F w/JLAB Holidays ReBaseline | SCIENTIST [80 h] | 6,014.4 | 2,561.69 |  |  |  |  |  | 3007.2 | CHUDAKOV | 1 | 1 | D |  | H | EUGENE C |  | 11-006 | 11-026 | 12-021 |  |  |  |  | 10-042 |  |  | 2531375 |  |  |  | 13-015 | PR |  | 14-001 |  |  | EJ |  |  |  |  |
| 2531227aa5 | Proc IO Modules (DAQ) Batch 2 | 42d | 2013-10-14 A | 2014-01-13 | 9-130M FS+228d, 9-140M |  | 42d | 2013-11-01 | 2014-01-13 | 182d |  | 8/5 M-F w/JLAB Holidays ReBaseline | PROCUREMENT<$50K 60 NO ESCALATION FY14 | 6,116.3 |  | 6116.3 | 0 | 0 | 100 |  | 0 | CHUDAKOV | 1 | 1 | D |  | D | EUGENE C |  | 11-006 | 11-026 | 12-021 |  |  |  |  | 10-042 | 12-055 |  | 2531227aa |  | 13-007 | EV | 13-015 | PR | OB-2 |  |  |  |  |  |  |  |  |
| 2531033 | Proc Servers for EPICS Archiving (DAQ) | 50d | 2013-10-21 A | 2014-01-24 | 9-140M | 50% | 50d | 2014-10-01 | 2014-12-11 | 671d | 294d | 8/5 M-F w/JLAB Holidays ReBaseline | PROCUREMENT<$50K 60 | 21,669.9 |  | 10834.95 | 10834.95 | 1083495 | 100 |  | 10834.95 | CHUDAKOV | 1 | 1 | D | APP | D | EUGENE C | 531 | 11-006 | 11-026 | 12-021 |  | 07-024 | 07-027 | 09-012 |  |  |  | 2531033 |  | 13-007 | VQ | 13-015 | PR | OB-2 | 14-001 |  |  |  |  |  |  |  |
| 2531097 | Install infiniband network (DAQ) | 42d | 2013-10-21 A | 2013-12-16 | 2531140 FS-15d | 30% | 30d | 2013-11-18 | 2014-01-29 | 164d | 57d | 8/5 M-F w/JLAB Holidays ReBaseline | SR STAFF [160 h] | 19,251.2 | 4,442.58 |  |  |  |  |  | 5775.36 | CHUDAKOV | 1 | 1 | D |  | S | EUGENE C |  | 11-006 | 11-026 | 12-021 | 12-054 |  |  |  | 10-042 |  |  | 2531097 |  | 13-007 |  | 13-015 | PR |  | 14-001 |  |  | PE | ST |  |  |  |
| 2531115 | Install VME CPUs FY13 | 67d | 2013-10-21 A | 2014-02-18 | 9-130M FS+228d, 9-140M | 25% | 67d | 2013-11-01 | 2014-02-18 | 17d | 0d | 8/5 M-F w/JLAB Holidays ReBaseline | SCIENTIST [58.18 h] | 4,373.97 | 517.97 |  |  |  |  |  | 1059.7487 | CHUDAKOV | 1 | 1 | D |  | S | EUGENE C |  | 11-006 | 11-026 | 12-021 | 12-054 |  |  |  | 10-042 |  |  | 2531115 |  | 13-007 |  | 13-015 | PR |  |  |  |  | PE | ST | 12-040 |  |  |
| 2531115a | Install VME CPUs FY14 | 67d | 2013-10-21 A | 2014-02-18 | 2531115 FS-67d | 25% | 67d | 2013-11-01 | 2014-02-18 | 17d | 0d | 8/5 M-F w/JLAB Holidays ReBaseline | SCIENTIST [261.82 h] | 19,683.63 | 2,330.96 |  |  |  |  |  | 4920.9069 | CHUDAKOV | 1 | 1 | D |  | S | EUGENE C |  | 11-006 | 11-026 | 12-021 | 12-054 |  |  |  | 10-042 |  |  | 2531115 |  | 13-007 |  | 13-015 | PR |  | 14-001 |  |  | PE | ST | 12-040 |  |  |
| 2531315 | Install Computing Infrastructure (DAQ) FY13 | 20d | 2013-10-21 A | 2013-12-16 | 9-130M FS+228d | 40% | 30d | 2013-11-01 | 2013-12-02 | 500d | 0d | 8/5 M-F w/JLAB Holidays ReBaseline | SR STAFF [43.84 h] | 5,274.83 | 1,217.27 |  |  |  |  |  | 2044.6976 | CHUDAKOV | 1 | 1 | D |  | S | EUGENE C |  | 11-006 | 11-026 | 12-021 |  |  |  |  | 10-042 |  |  | 2531315 |  |  |  | 13-015 | PR |  |  |  |  | PE | ST |  |  |  |
| 2531315a | Install Computing Infrastructure (DAQ) FY14 | 53d | 2013-10-21 A | 2013-12-16 | 2531315 FS-40d | 40% | 30d | 2013-12-03 | 2014-02-26 | 521d | 21d | 8/5 M-F w/JLAB Holidays ReBaseline | SR STAFF [116.16 h] | 13,976.37 | 3,225.32 |  |  |  |  |  | 5590.54848 | CHUDAKOV | 1 | 1 | D |  | S | EUGENE C |  | 11-006 | 11-026 | 12-021 |  |  |  |  | 10-042 |  |  | 2531315 |  |  |  | 13-015 | PR |  | 14-001 |  |  | PE | ST |  |  |  |
| 2531005fa | Proc Single Board Computing Remaining items (DAQ) Phase 2 | 55d | 2013-11-01 | 2014-01-31 | 9-140M FS+23d |  |  |  |  | 108d | 13d | 8/5 M-F w/JLAB Holidays ReBaseline | PROCUREMENT<$50K 60; PROCUREMENT>$50K 69 | 159,638.03 |  | 159638.03 | 0 | 0 | 100 |  | 0 | CHUDAKOV | 1 | 1 | D | APP | D | EUGENE C | 531 | 11-006 | 11-026 | 12-021 | 12-054F |  |  |  |  |  |  | 2531005fa |  | 13-007 | EV | 13-015 | PR |  | 14-001 |  |  |  |  |  |  |  |
| 2531065 | Proc Fibers for Counting House to Hall (DAQ) PR FY13 | 1d | 2013-11-01 | 2013-11-01 | 9-130M FS+228d, 9-140M FS+10d |  |  |  |  | 2d | 0d | 8/5 M-F w/JLAB Holidays ReBaseline | SR STAFF [27.59 h] | 3,319.63 |  |  |  |  |  |  | 0 | CHUDAKOV | 1 | 1 | D | APP | H | EUGENE C | 531 | 11-006 | 11-026 | 12-021F | 12-054F |  |  |  |  |  |  | 2531065 |  | 13-007F |  | 13-015 | PR |  |  |  |  | PE |  |  |  |  |
| 2531065a | Proc Fibers for Counting House to Hall (DAQ) PR FY14 | 1d | 2013-11-01 | 2013-11-01 | 2531065 FS-1d |  |  |  |  | 33d | 31d | 8/5 M-F w/JLAB Holidays ReBaseline | SR STAFF [12.41 h] | 1,493.17 |  |  |  |  |  |  | 0 | CHUDAKOV | 1 | 1 | D | APP | H | EUGENE C | 531 | 11-006 | 11-026 | 12-021F | 12-054F |  |  |  |  |  |  | 2531065 |  | 13-007F |  | 13-015 | PR |  | 14-001 |  |  | PE |  |  |  |  |
| 2531178 | Software Licenses and Fees | 223d | 2013-11-01 | 2014-09-29 | 9-140M |  |  |  |  | 1d |  | 8/5 M-F w/JLAB Holidays ReBaseline | PROCUREMENT<$50K 60 | 1,857.42 |  | 1857.42 | 0 | 0 | 100 |  | 0 | CHUDAKOV | 1 | 1 | D |  | D | EUGENE C |  | 11-006 | 11-026 | 12-021 |  |  |  |  | 10-042 |  |  | 2531178 |  |  | PE | 13-015 | PR |  | 14-001 |  |  |  |  |  |  |  |
| 2531310 | Install DAQ Equipment in Hall (DAQ) | 64d | 2013-11-01 | 2014-02-13 | 2562405 FS-32d |  |  |  |  | 20d | 3d | 8/5 M-F w/JLAB Holidays ReBaseline | SCIENTIST [160 h] | 12,028.8 |  |  |  |  |  |  | 0 | CHUDAKOV | 1 | 1 | D |  | S | EUGENE C |  | 11-006 | 11-026 | 12-021 |  |  |  |  | 10-042 |  |  | 2531310 |  |  |  | 13-015 | PR |  | 14-001 |  |  | EJ | ST |  |  |  |
| 2531165 | Install VME based electronic for Controls/Monitoring FY13 | 43d | 2013-11-18 | 2014-01-30 | 9-140M FS+34d, 9-130M FS+228d |  |  |  |  | 43d | 0d | 8/5 M-F w/JLAB Holidays ReBaseline | SCIENTIST [32.99 h] | 2,480.19 |  |  |  |  |  |  | 0 | CHUDAKOV | 1 | 1 | D |  | S | EUGENE C |  | 11-006 | 11-026 | 12-021 |  |  |  |  | 10-042 |  |  | 2531165 |  |  |  | 13-015 | PR |  |  |  |  | PE | ST |  |  |  |
| 2531165a | Install VME based electronic for Controls/Monitoring FY14 | 43d | 2013-11-18 | 2014-01-30 | 2531165 FS-43d |  |  |  |  | 43d | 32d | 8/5 M-F w/JLAB Holidays ReBaseline | SCIENTIST [127.01 h] | 9,548.61 |  |  |  |  |  |  | 0 | CHUDAKOV | 1 | 1 | D |  | S | EUGENE C |  | 11-006 | 11-026 | 12-021 |  |  |  |  | 10-042 |  |  | 2531165 |  |  |  | 13-015 | PR |  | 14-001 |  |  | PE | ST |  |  |  |
| 2531088 | Procure and Install cameras in the hall (DAQ) | 49d | 2013-12-02 | 2014-02-19 | 9-140M FS+42d |  |  |  |  | 156d |  | 8/5 M-F w/JLAB Holidays ReBaseline | ELEC ENG [40 h]; PROCUREMENT<$50K 60 | 23,643.2 |  | 20638 | 0 | 0 | 100 |  | 0 | CHUDAKOV | 1 | 1 | D | APP | D | EUGENE C | 531 | 11-006 | 11-026 | 12-021 | 12-054F |  |  |  |  |  |  | 2531088 |  | 13-007 | CP | 13-015 | PR |  | 14-001 |  |  | PE |  |  |  |  |
| 2531100 | Install DAQ fibers to switches (DAQ) | 68d | 2013-12-02 | 2014-03-18 | 9-140M FS+42d |  |  |  |  | 107d | 0d | 8/5 M-F w/JLAB Holidays ReBaseline | PROCUREMENT<$50K 60 | 19,695.88 |  | 19695.88 | 0 | 0 | 100 |  | 0 | CHUDAKOV | 1 | 1 | D |  | D | EUGENE C |  | 11-006 | 11-026 | 12-021 | 12-054 |  |  |  | 10-042 |  |  | 2531100 |  | 13-007 | EV | 13-015 | PR |  | 14-001 |  |  |  |  |  |  |  |
| 2531047 | Proc Telecom Installation (DAQ) | 14d | 2013-12-03 | 2013-12-20 | 9-140M FS+43d, 9-130M FS+228d |  |  |  |  | 23d | 21d | 8/5 M-F w/JLAB Holidays ReBaseline | PROCUREMENT<$50K 60 NO ESCALATION FY14 | 3,150 |  | 3150 | 0 | 0 | 100 |  | 0 | CHUDAKOV | 1 | 1 | D | APP | D | EUGENE C | 531 | 11-006 | 11-026 | 12-021 | 12-054 |  |  |  |  |  |  | 2531047 |  | 13-007 | PE | 13-015 | PR |  |  |  |  |  |  |  |  |  |
| 2531400 | Procure and Install Voltage Chassis Remote Reset | 59d | 2013-12-05 | 2014-03-10 | 9-140M FS+45d |  |  |  |  | 143d |  | 8/5 M-F w/JLAB Holidays ReBaseline | PROCUREMENT<$50K 60; ELEC TECH [40 h] | 4,325.2 |  | 2445.6 | 0 | 0 | 100 |  | 0 | CHUDAKOV | 1 | 1 | D |  | D | EUGENE C |  | 11-006 | 11-026 | 12-021 |  |  |  |  | 10-042 |  |  | 2531400 |  |  | PE | 13-015 | PR |  | 14-001 |  |  | EJ |  |  |  |  |
| 2531070 | Proc Fibers for Counting House to Hall (DAQ) | 24d | 2013-12-19 | 2014-02-03 | 2531065a, 2531065 FS+31d |  |  |  |  | 2d | 0d | 8/5 M-F w/JLAB Holidays ReBaseline | PROCUREMENT<$50K 60 | 35,743.98 |  | 35743.98 | 0 | 0 | 100 |  | 0 | CHUDAKOV | 1 | 1 | D | APP | D | EUGENE C | 531 | 11-006 | 11-026 | 12-021 | 12-054 |  |  |  |  |  |  | 2531070 |  | 13-007 | EV | 13-015 | PR |  | 14-001 |  |  |  |  |  |  |  |
| 2531360 | Patch Panels and Cu Cables to CH (DAQ) | 84d | 2014-01-03 | 2014-05-01 | 9-140M FS+60d, 2562645 FS+5d, 2562645a FS+5d |  |  |  |  | 105d |  | 8/5 M-F w/JLAB Holidays ReBaseline | MECH TECH [40 h]; PROCUREMENT<$50K 60 | 5,504.45 |  | 3611.65 | 0 | 0 | 100 |  | 0 | CHUDAKOV | 1 | 1 | D |  | D | EUGENE C |  | 11-006 | 11-026 | 12-021 |  |  |  |  | 10-042 |  |  | 2531360 |  |  | CP | 13-015 | PR |  | 14-001 |  |  | PE |  |  |  |  |
| 2531395 | Procure Small UPSs for Tagger Hall and Hall D Cables (DAQ) | 77d | 2014-01-03 | 2014-04-22 | 9-140M FS+60d |  |  |  |  | 112d |  | 8/5 M-F w/JLAB Holidays ReBaseline | PROCUREMENT<$50K 60 | 21,648.23 |  | 21648.23 | 0 | 0 | 100 |  | 0 | CHUDAKOV | 1 | 1 | D |  | S | EUGENE C |  | 11-006 | 11-026 | 12-021 |  |  |  |  | 10-042 |  |  | 2531395 |  |  | CP | 13-015 | PR |  | 14-001 |  |  |  | ST |  |  |  |
| 2531365 | Sys Admin Support (DAQ) | 188d | 2014-01-06 | 2014-09-30 | 2531315a FS-15d, 2531315 FS+6d |  |  |  |  | 500d |  | 8/5 M-F w/JLAB Holidays ReBaseline | SR STAFF [160 h] | 19,251.2 |  |  |  |  |  |  | 0 | CHUDAKOV | 1 | 1 | D |  | E | EUGENE C |  | 11-006 | 11-026 | 12-021 |  |  |  |  | 10-042 |  |  | 2531365 |  |  |  | 13-015 | PR |  | 14-001 | 100 | 100 | PE |  |  | 100 | 0 |
| 2531105 | Install Trigger Electrnc's (DAQ) FY13 | 83d | 2014-01-10 | 2014-05-07 | 9-130M FS+228d, 9-140M FS+65d |  |  |  |  | 19d | 0d | 8/5 M-F w/JLAB Holidays ReBaseline | ELEC ENG [8.57 h]; SCIENTIST [29.99 h]; ELEC TECH [38.55 h] | 4,709.84 |  |  |  |  |  |  | 0 | CHUDAKOV | 1 | 1 | D |  | S | EUGENE C |  | 11-006 | 11-026 | 12-021 | 12-054 |  |  |  |  |  |  | 2531105 |  | 13-007 |  | 13-015 | PR |  |  |  |  | PE | ST |  |  |  |
| 2531105a | Install Trigger Electrnc's (DAQ) FY14 | 83d | 2014-01-10 | 2014-05-07 | 2531105 FS-83d |  |  |  |  | 19d | 0d | 8/5 M-F w/JLAB Holidays ReBaseline | ELEC ENG [70.36 h]; SCIENTIST [211.08 h]; ELEC TECH [281.44 h] | 34,380.01 |  |  |  |  |  |  | 0 | CHUDAKOV | 1 | 1 | D |  | S | EUGENE C |  | 11-006 | 11-026 | 12-021 | 12-054 |  |  |  |  |  |  | 2531105 |  | 13-007 |  | 13-015 | PR |  | 14-001 |  |  | PE | ST |  |  |  |
| 2531089 | Procure Conference Equipment (DAQ) | 75d | 2014-02-03 | 2014-05-16 | 9-140M FS+80d |  |  |  |  | 94d |  | 8/5 M-F w/JLAB Holidays ReBaseline | PROCUREMENT<$50K 60 | 11,178.78 |  | 11178.78 | 0 | 0 | 100 |  | 0 | CHUDAKOV | 1 | 1 | D | APP | D | EUGENE C | 531 | 11-006 | 11-026 | 12-021 | 12-054F |  |  |  |  |  |  | 2531089 |  | 13-007 | PE | 13-015 | PR |  | 14-001 |  |  |  |  |  |  |  |
| 2531380 | Check-out Cabling (DAQ) | 30d | 2014-03-19 | 2014-04-29 | 2531097, 2531100 |  |  |  |  | 107d |  | 8/5 M-F w/JLAB Holidays ReBaseline | SR STAFF [80 h] | 9,625.6 |  |  |  |  |  |  | 0 | CHUDAKOV | 1 | 1 | D |  | H | EUGENE C |  | 11-006 | 11-026 | 12-021 |  |  |  |  | 10-042 |  |  | 2531380 |  |  |  | 13-015 | PR |  | 14-001 |  |  | PE |  |  |  |  |
| 2531370 | Check-out Online Computers (DAQ) | 40d | 2014-03-21 | 2014-05-15 | 2531005fa FS+21d, 2531027, 2531005f FS+21d, 2531340, 2531022, 2531330 |  |  |  |  | 95d |  | 8/5 M-F w/JLAB Holidays ReBaseline | SCIENTIST [40 h]; MECH TECH [120 h] | 8,685.6 |  |  |  |  |  |  | 0 | CHUDAKOV | 1 | 1 | D |  | H | EUGENE C |  | 11-006 | 11-026 | 12-021 |  |  |  |  | 10-042 |  |  | 2531370 |  |  |  | 13-015 | PR |  | 14-001 |  |  | PE |  |  |  |  |
| 2531385 | Check-out DAQ Hardware (DAQ) | 110d | 2014-04-02 | 2014-09-05 | 2531310 FS+30d, 2531115a FS+30d, 2531115 FS+30d |  |  |  |  | 17d |  | 8/5 M-F w/JLAB Holidays ReBaseline | SCIENTIST [120 h] | 9,021.6 |  |  |  |  |  |  | 0 | CHUDAKOV | 1 | 1 | D |  | S | EUGENE C |  | 11-006 | 11-026 | 12-021 |  |  |  |  | 10-042 |  |  | 2531385 |  |  |  | 13-015 | PR |  | 14-001 |  |  | EJ |  |  |  |  |
| 2531125 | Check-out Trigger Electrnc's (DAQ) | 63d | 2014-05-08 | 2014-08-06 | 2531105, 2531105a |  |  |  |  | 19d | 0d | 8/5 M-F w/JLAB Holidays ReBaseline | ELEC ENG [80 h]; SCIENTIST [360 h]; ELEC TECH | 33,075.2 |  |  |  |  |  |  | 0 | CHUDAKOV | 1 | 1 | D |  | S | EUGENE C |  | 11-006 | 11-026 | 12-021 | 12-054 |  |  |  |  |  |  | 2531125 |  | 13-007 |  | 13-015 | PR |  | 14-001 |  |  | EJ |  |  |  |  |

Notes:
- 2531227aa: Explanation: Holding 18K from 227 12/20/12
- 2531227aa5: Explanation: Holding 18K from 227 12/20/12
- 2531097: Steps: Install and connect hardware (done); Install Linux drivers; Check CODA with new IB
- 2531115: Steps: Create OS directory system for TFTP booting (done); Configure and test CPU boards; Intall and connect CPU boards; Ducumentation
- 2531115a: Steps: Create OS directory system for TFTP booting (done); Configure and test CPU boards; Intall and connect CPU boards; Ducumentation
- 2531315: Steps: Install new Hall D servers; Install RAIDs (done); Connect network cables (done)
- 2531315a: Steps: Install new Hall D servers; Install RAIDs (done); Connect network cables (done)
- 2531310: Steps: Install switches in the racks; Install cables to ROCs; Program switches
- 2531165: Steps: Program V1495 boards; Install VME crates and boards; Verify Struck scaler feedback; Integrate with Hall D EPICS framework
- 2531165a: Steps: Program V1495 boards; Install VME crates and boards; Verify Struck scaler feedback; Integrate with Hall D EPICS framework
- 2531395: Steps: Prepare PR; Procure UPS; Connect power cables
- 2531105: Steps: Install crates in the hall; Initialize 0-latency trigger; Integrate with DAQ
- 2531105a: Steps: Install crates in the hall; Initialize 0-latency trigger; Integrate with DAQ

| ID | WBS | Activity | Duration | Start | Finish | Predecessors | Complete | Planned start | Planned finish | Resources | Cost | Actual cost | Calculated Remaining Total Cost | MONTHLY EV COST | RESP - Responsibility | STRT%COMP for CM EVM | FNSH%COMP for CM EVM | HALL D Related Milestones | EVMS Reporting Codes | CAM RESPONSIBLE | Activities with Steps | CR 11-006 | CR 11-026 | CR 12-001 | CR 12-021 | CR 12-054 | MARCH!!! | LOE % Pre Calc | LOE % | LOE Divider | LOE Multiplier | CR 07-024 | CR 12-053 | CR 07-027 | 12 GEV MAJOR PROCUREMENT CATAGORY | Remaining Material Cost Based on % Compl | Claimed Material Cost Based on % Complet | Initial Claimed Material Calc | Claimed Material Divider | CR 12-055 |
| --- | --- | --- | --- | --- | --- | --- | --- | --- | --- | --- | --- | --- | --- | --- | --- | --- | --- | --- | --- | --- | --- | --- | --- | --- | --- | --- | --- | --- | --- | --- | --- | --- | --- | --- | --- | --- | --- | --- | --- | --- |
|  | 2 | **1.5.3.2 ONLINE COMPUTING** |  | 2011-04-01 | 2014-09-30 |  |  |  |  |  |  |  |  |  |  |  |  |  |  |  |  |  |  |  |  |  |  |  |  |  |  |  |  |  |  |  |  |  |  |  |
| 1532035b |  | Plan Monitoring Histograms FY11 | 296d | 2011-04-01 A | 2012-06-11 A | 9-110M | 100% | 2011-04-01 | 2012-06-08 | SCIENTIST [55.26 h] | 3,849.81 | 3,858.38 | 0 | 3781.4418 | CHUDAKOV | 1 | 1 | D | S | EUGENE C | ST | 11-006 | 11-026 | 12-001 | 12-021F | 12-054F |  |  |  |  |  |  |  |  |  |  |  |  |  |  |
| 1532035ba |  | Plan Monitoring Histograms FY12 | 297d | 2011-04-01 A | 2012-06-11 A | 1532035b FS-165d | 100% |  |  | SCIENTIST [104.74 h] | 7,297.29 | 7,297.29 | 0 | 7395.6914 | CHUDAKOV | 1 | 1 | D | S | EUGENE C | ST | 11-006 | 11-026 | 12-001 | 12-021F | 12-054F |  |  |  |  |  |  |  |  |  |  |  |  |  |  |
| 1532060g |  | Plan Experiment Controls Motors FY11 | 278d | 2011-04-01 A | 2012-05-14 A | 9-110M FS+120d | 100% | 2011-04-01 | 2012-05-11 | SCIENTIST [82.58 h] | 5,748.08 | 5,768.7 | 0 | 5650.9494 | CHUDAKOV | 1 | 1 | D | S | EUGENE C | ST | 11-006 | 11-026 | 12-001 |  |  |  |  |  |  |  |  |  |  |  |  |  |  |  |  |
| 1532060ga |  | Plan Experiment Controls Motors FY12 | 279d | 2011-04-01 A | 2012-05-14 A | 1532060g FS-120d | 100% |  |  | SCIENTIST [77.42 h] | 5,389.2 | 5,389.2 | 0 | 5466.6262 | CHUDAKOV | 1 | 1 | D | S | EUGENE C | ST | 11-006 | 11-026 | 12-001 |  |  |  |  |  |  |  |  |  |  |  |  |  |  |  |  |
| 1532060a |  | Plan Experiment Controls Display management FY11 | 344d | 2011-05-01 A | 2012-09-17 A | 9-110M FS+120d | 100% | 2011-05-02 | 2012-09-14 | SCIENTIST [61.94 h] | 4,331.58 | 4,365.27 | 0 | 4238.5542 | CHUDAKOV | 1 | 1 | D | S | EUGENE C | ST | 11-006 | 11-026 | 12-001 | 12-021F |  |  |  |  |  |  |  |  |  |  |  |  |  |  |  |
| 1532060aa |  | Plan Experiment Controls Display management FY12 | 345d | 2011-05-01 A | 2012-09-17 A | 1532060a FS-120d | 100% | 2011-05-02 | 2012-09-17 | SCIENTIST [58.06 h] | 4,060.36 | 4,060.36 | 0 | 4099.6166 | CHUDAKOV | 1 | 1 | D | S | EUGENE C | ST | 11-006 | 11-026 | 12-001 | 12-021F |  |  |  |  |  |  |  |  |  |  |  |  |  |  |  |
| 1532060h |  | Plan Experiment Controls Gas Systems FY11 | 435d | 2011-05-01 A | 2013-03-11 A | 9-110M FS+120d | 100% | 2011-05-02 | 2013-02-01 | SCIENTIST [82.58 h] | 5,821.29 | 5,845.24 | 0 | 5650.9494 | CHUDAKOV | 1 | 1 | D | S | EUGENE C | ST | 11-006 | 11-026 | 12-001 | 12-021F |  | XX |  |  |  |  |  |  |  |  |  |  |  |  |  |
| 1532060ha |  | Plan Experiment Controls Gas Systems FY12 | 435d | 2011-05-01 A | 2013-03-11 A | 1532060h FS-120d | 100% | 2011-05-02 | 2013-02-01 | SCIENTIST [77.42 h] | 5,457.55 | 5,476.73 | 0 | 5466.6262 | CHUDAKOV | 1 | 1 | D | S | EUGENE C | ST | 11-006 | 11-026 | 12-001 | 12-021F |  | XX |  |  |  |  |  |  |  |  |  |  |  |  |  |
| 1532045a |  | Plan Archiving Run Info | 255d | 2011-06-01 A | 2012-06-11 A | 9-120M FS-70d | 100% |  |  | SCIENTIST [200 h] | 13,974.96 | 13,974.96 | 0 | 14122 | CHUDAKOV | 1 | 1 | D | S | EUGENE C | ST | 11-006 | 11-026 |  | 12-021F |  |  |  |  |  |  |  |  |  |  |  |  |  |  |  |
| 1532060 |  | Plan Experiment Controls Framework FY11 (FY12 @ 1532060p) | 363d | 2011-06-01 A | 2012-11-12 A | 9-110M FS+120d | 100% | 2011-06-01 | 2012-11-09 | SCIENTIST [82.58 h] | 5,803.68 | 5,830.37 | 0 | 5650.9494 | CHUDAKOV | 1 | 1 | D | S | EUGENE C | ST | 11-006 | 11-026 | 12-001 |  |  |  |  |  |  |  |  |  |  |  |  |  |  |  |  |
| 1532060p |  | Plan Experiment Controls Framework FY12 (FY11 @ 1532060) | 364d | 2011-06-01 A | 2012-11-12 A | 1532060 FS-120d | 100% |  |  | SCIENTIST [77.42 h] | 5,441.59 | 5,441.59 | 0 | 5466.6262 | CHUDAKOV | 1 | 1 | D | S | EUGENE C | ST | 11-006 | 11-026 | 12-001 |  |  |  |  |  |  |  |  |  |  |  |  |  |  |  |  |
| 1532011E |  | FY11 Travel (ONLINE COMP) | 64d | 2011-07-01 A | 2011-09-30 A | 9-110M FS+184d | 100% |  |  | TRAVEL | 385.51 |  | 0 | 385.51 | CHUDAKOV | 1 | 1 | D | E | EUGENE C |  |  | 11-026 |  |  |  |  | 32.8125 | 67.1875 | 100 | 100 | 07-024 |  |  |  |  |  |  |  |  |
| 1532025 |  | Plan Front-End Software FY11 | 390d | 2011-07-01 A | 2013-08-30 A | 9-110M FS+204d | 100% | 2011-07-01 | 2013-01-30 | SCIENTIST [157.83 h] | 11,159.85 | 11,253.64 | 8100.230175 | 10800.3069 | CHUDAKOV | 1 | 1 | D | S | EUGENE C | ST | 11-006 | 11-026 | 12-001 | 12-021F |  | XX |  |  |  |  |  |  |  |  |  |  |  |  |  |
| 1532025a |  | Plan Front-End Software FY12 | 390d | 2011-07-01 A | 2013-08-15 A | 1532025 FS-140d | 100% | 2011-07-01 | 2013-01-30 | SCIENTIST [502.17 h] | 35,507.45 | 35,789.89 | 26593.667775 | 35458.2237 | CHUDAKOV | 1 | 1 | D | S | EUGENE C | ST | 11-006 | 11-026 | 12-001 | 12-021F |  | XX |  |  |  |  |  |  |  |  |  |  |  |  |  |
| 1532030 |  | Plan DAQ Software Event Unblocking FY11 (FY12 @ 1532030d) | 214d | 2011-07-01 A | 2012-05-14 A | 9-110M FS+204d | 100% | 2011-07-01 | 2012-05-11 | SCIENTIST [86.09 h] | 6,022.69 | 6,067.69 | 0 | 5891.1387 | CHUDAKOV | 1 | 1 | D | S | EUGENE C | ST | 11-006 | 11-026 | 12-001 | 12-021F | 12-054F |  |  |  |  |  |  |  |  |  |  |  |  |  |  |
| 1532030a |  | Plan DAQ Software Scripts FY11 | 131d | 2011-07-01 A | 2012-01-16 A | 9-110M FS+204d | 100% | 2011-07-01 | 2012-01-13 | SCIENTIST [57.39 h] | 3,991.19 | 4,025.4 | 0 | 3927.1977 | CHUDAKOV | 1 | 1 | D | S | EUGENE C | ST | 11-006 | 11-026 | 12-001 | 12-021F | 12-054F |  |  |  |  |  |  |  |  |  |  |  |  |  |  |
| 1532030aa |  | Plan DAQ Software Scripts FY12 | 131d | 2011-07-01 A | 2012-01-16 A | 1532030a FS-140d | 100% | 2011-07-01 | 2012-01-13 | SCIENTIST [182.61 h] | 12,699.61 | 12,699.61 | 0 | 12894.0921 | CHUDAKOV | 1 | 1 | D | S | EUGENE C | ST | 11-006 | 11-026 | 12-001 | 12-021F | 12-054F |  |  |  |  |  |  |  |  |  |  |  |  |  |  |
| 1532030b |  | Plan DAQ Software Run Control FY11 | 232d | 2011-07-01 A | 2012-06-11 A | 9-110M FS+204d | 100% | 2011-07-01 | 2012-06-08 | SCIENTIST [47.83 h] | 3,348.51 | 3,377.27 | 0 | 3273.0069 | CHUDAKOV | 1 | 1 | D | S | EUGENE C | ST | 11-006 | 11-026 | 12-001 |  | 12-054F |  |  |  |  |  |  |  |  |  |  |  |  |  |  |
| 1532030ba |  | Plan DAQ Software Run Control FY12 | 233d | 2011-07-01 A | 2012-06-11 A | 1532030b FS-140d | 100% |  |  | SCIENTIST [152.17 h] | 10,653.6 | 10,653.6 | 0 | 10744.7237 | CHUDAKOV | 1 | 1 | D | S | EUGENE C | ST | 11-006 | 11-026 | 12-001 |  | 12-054F |  |  |  |  |  |  |  |  |  |  |  |  |  |  |
| 1532030c |  | Plan DAQ Software Code Management FY11 | 131d | 2011-07-01 A | 2012-01-16 A | 9-110M FS+204d | 100% | 2011-07-01 | 2012-01-13 | SCIENTIST [38.26 h] | 2,660.79 | 2,683.6 | 0 | 2618.1318 | CHUDAKOV | 1 | 1 | D | S | EUGENE C | ST | 11-006 | 11-026 | 12-001 | 12-021F | 12-054F |  |  |  |  |  |  |  |  |  |  |  |  |  |  |
| 1532030ca |  | Plan DAQ Software Code Management FY12 | 131d | 2011-07-01 A | 2012-01-16 A | 1532030c FS-140d | 100% | 2011-07-01 | 2012-01-13 | SCIENTIST [121.74 h] | 8,466.4 | 8,466.4 | 0 | 8596.0614 | CHUDAKOV | 1 | 1 | D | S | EUGENE C | ST | 11-006 | 11-026 | 12-001 | 12-021F | 12-054F |  |  |  |  |  |  |  |  |  |  |  |  |  |  |
| 1532030d |  | Plan DAQ Software Event Unblocking FY12 (FY11 @ 1532030) | 215d | 2011-07-01 A | 2012-05-14 A | 1532030 FS-140d | 100% |  |  | SCIENTIST [273.91 h] | 19,163.04 | 19,163.04 | 0 | 19340.7851 | CHUDAKOV | 1 | 1 | D | S | EUGENE C | ST | 11-006 | 11-026 | 12-001 | 12-021F | 12-054F |  |  |  |  |  |  |  |  |  |  |  |  |  |  |
| 1532035 |  | Plan Monitoring Framework FY11 (FY12 @ 1532035h) | 390d | 2011-07-01 A | 2013-02-11 A | 9-110M FS+162d | 100% | 2011-07-01 | 2013-01-30 | SCIENTIST [82.89 h] | 5,860.99 | 5,891.02 | 0 | 5672.1627 | CHUDAKOV | 1 | 1 | D | S | EUGENE C | ST | 11-006 | 11-026 | 12-001 | 12-021F | 12-054F | XX |  |  |  |  |  |  |  |  |  |  |  |  |  |
| 1532035a |  | Plan Monitoring Scalers FY11 | 117d | 2011-07-01 A | 2011-12-19 A | 9-110M FS+162d | 100% | 2011-07-01 | 2011-12-16 | SCIENTIST [41.45 h] | 2,877.36 | 2,917.89 | 0 | 2836.4235 | CHUDAKOV | 1 | 1 | D | S | EUGENE C | ST | 11-006 | 11-026 | 12-001 | 12-021F | 12-054F |  |  |  |  |  |  |  |  |  |  |  |  |  |  |
| 1532035aa |  | Plan Monitoring Scalers FY12 | 118d | 2011-07-01 A | 2011-12-19 A | 1532035a FS-165d | 100% |  |  | SCIENTIST [78.55 h] | 5,453.54 | 5,453.54 | 0 | 5546.4155 | CHUDAKOV | 1 | 1 | D | S | EUGENE C | ST | 11-006 | 11-026 | 12-001 | 12-021F | 12-054F |  |  |  |  |  |  |  |  |  |  |  |  |  |  |
| 1532035c |  | Plan Monitoring Remote FY11 | 390d | 2011-07-01 A | 2013-07-15 A | 9-110M FS+162d | 100% | 2011-07-01 | 2013-01-30 | SCIENTIST [41.45 h] | 2,930.85 | 2,962.53 | 2836.4235 | 2836.4235 | CHUDAKOV | 1 | 1 | D | S | EUGENE C | ST | 11-006 | 11-026 | 12-001 | 12-021F | 12-054F | XX |  |  |  |  |  |  |  |  |  |  |  |  |  |
| 1532035ca |  | Plan Monitoring Remote FY12 | 390d | 2011-07-01 A | 2013-07-15 A | 1532035c FS-165d | 100% | 2011-07-01 | 2013-01-30 | SCIENTIST [78.55 h] | 5,554.12 | 5,592.61 | 5546.4155 | 5546.4155 | CHUDAKOV | 1 | 1 | D | S | EUGENE C | ST | 11-006 | 11-026 | 12-001 | 12-021F | 12-054F | XX |  |  |  |  |  |  |  |  |  |  |  |  |  |
| 1532035d |  | Plan Monitoring Hardware Status FY11 | 390d | 2011-07-01 A | 2013-08-30 A | 9-110M FS+162d | 100% | 2011-07-01 | 2013-01-30 | SCIENTIST [55.26 h] | 3,907.33 | 3,943.99 | 2268.86508 | 3781.4418 | CHUDAKOV | 1 | 1 | D | S | EUGENE C | ST | 11-006 | 11-026 | 12-001 | 12-021F | 12-054F | XX |  |  |  |  |  |  |  |  |  |  |  |  |  |
| 1532035da |  | Plan Monitoring Hardware Status FY12 | 390d | 2011-07-01 A | 2013-08-30 A | 1532035d FS-165d | 100% | 2011-07-01 | 2013-01-30 | SCIENTIST [104.74 h] | 7,405.96 | 7,468.27 | 4437.41484 | 7395.6914 | CHUDAKOV | 1 | 1 | D | S | EUGENE C | ST | 11-006 | 11-026 | 12-001 | 12-021F | 12-054F | XX |  |  |  |  |  |  |  |  |  |  |  |  |  |
| 1532035f |  | Plan Monitoring Process Status FY11 | 390d | 2011-07-01 A | 2013-07-15 A | 9-110M FS+162d | 100% | 2011-07-01 | 2013-01-30 | SCIENTIST [41.45 h] | 2,930.85 | 2,955.49 | 1843.675275 | 2836.4235 | CHUDAKOV | 1 | 1 | D | S | EUGENE C | ST | 11-006 | 11-026 | 12-001 | 12-021F | 12-054F | XX |  |  |  |  |  |  |  |  |  |  |  |  |  |
| 1532035fa |  | Plan Monitoring Process Status FY12 | 390d | 2011-07-01 A | 2013-07-15 A | 1532035f FS-165d | 100% | 2011-07-01 | 2013-01-30 | SCIENTIST [78.55 h] | 5,554.12 | 5,592.61 | 3605.170075 | 5546.4155 | CHUDAKOV | 1 | 1 | D | S | EUGENE C | ST | 11-006 | 11-026 | 12-001 | 12-021F | 12-054F | XX |  |  |  |  |  |  |  |  |  |  |  |  |  |
| 1532035g |  | Plan Monitoring Trigger FY11 | 390d | 2011-07-01 A | 2013-02-11 A | 9-110M FS+162d | 100% | 2011-07-01 | 2013-01-30 | SCIENTIST [27.63 h] | 1,953.66 | 1,963.67 | 0 | 1890.7209 | CHUDAKOV | 1 | 1 | D | S | EUGENE C | ST | 11-006 | 11-026 | 12-001 | 12-021F | 12-054F | XX |  |  |  |  |  |  |  |  |  |  |  |  |  |
| 1532035ga |  | Plan Monitoring Trigger FY12 | 390d | 2011-07-01 A | 2013-02-11 A | 1532035g FS-165d | 100% | 2011-07-01 | 2013-01-30 | SCIENTIST [52.37 h] | 3,702.98 | 3,705.24 | 0 | 3697.8457 | CHUDAKOV | 1 | 1 | D | S | EUGENE C | ST | 11-006 | 11-026 | 12-001 | 12-021F | 12-054F | XX |  |  |  |  |  |  |  |  |  |  |  |  |  |
| 1532035h |  | Plan Monitoring Framework FY12 (FY11 @ 1532035) | 390d | 2011-07-01 A | 2013-02-11 A | 1532035 FS-165d | 100% | 2011-07-01 | 2013-01-30 | SCIENTIST [157.11 h] | 11,108.94 | 11,115.73 | 0 | 11093.5371 | CHUDAKOV | 1 | 1 | D | S | EUGENE C | ST | 11-006 | 11-026 | 12-001 | 12-021F | 12-054F | XX |  |  |  |  |  |  |  |  |  |  |  |  |  |
| 1532050 |  | Plan Event Display FY11 | 277.76d | 2011-07-01 A | 2012-08-13 A | 9-110M FS+184d | 100% |  |  | SCIENTIST [28.29 h]; CONTRB UNIV LBR [155.58 h] | 1,983.35 | 1,983.35 | 0 | 1935.8847 | CHUDAKOV | 1 | 1 | D | S | EUGENE C | ST | 11-006 | 11-026 | 12-001 |  |  |  |  |  |  |  |  |  |  |  |  |  |  |  |  |
| 1532050a |  | Plan Event Display FY12 | 278d | 2011-07-01 A | 2012-08-13 A | 1532050 FS-120d | 100% |  |  | SCIENTIST [51.71 h]; CONTRB UNIV LBR [284.42 h] | 3,625.29 | 3,625.29 | 0 | 3651.2431 | CHUDAKOV | 1 | 1 | D | S | EUGENE C | ST | 11-006 | 11-026 | 12-001 |  |  |  |  |  |  |  |  |  |  |  |  |  |  |  |  |
| 1532060b |  | Plan Experiment Controls Backup/Restore FY11 | 390d | 2011-07-01 A | 2012-12-17 A | 9-110M FS+120d | 100% | 2011-07-01 | 2013-01-30 | SCIENTIST [61.94 h] | 4,379.65 | 4,394.5 | 0 | 4238.5542 | CHUDAKOV | 1 | 1 | D | S | EUGENE C | ST | 11-006 | 11-026 | 12-001 | 12-021F |  |  |  |  |  |  |  |  |  |  |  |  |  |  |  |
| 1532060ba |  | Plan Experiment Controls Backup/Restore FY12 | 390d | 2011-07-01 A | 2012-12-17 A | 1532060b FS-120d | 100% | 2011-07-01 | 2013-01-30 | SCIENTIST [58.06 h] | 4,105.31 | 4,096.75 | 0 | 4099.6166 | CHUDAKOV | 1 | 1 | D | S | EUGENE C | ST | 11-006 | 11-026 | 12-001 | 12-021F |  |  |  |  |  |  |  |  |  |  |  |  |  |  |  |
| 1532060c |  | Plan Experiment Controls Magnet PS FY11 | 301d | 2011-07-01 A | 2012-09-17 A | 9-110M FS+120d | 100% | 2011-07-01 | 2012-09-14 | SCIENTIST [82.58 h] | 5,792.7 | 5,874.48 | 0 | 5650.9494 | CHUDAKOV | 1 | 1 | D | S | EUGENE C | ST | 11-006 | 11-026 | 12-001 | 12-021F |  |  |  |  |  |  |  |  |  |  |  |  |  |  |  |
| 1532060ca |  | Plan Experiment Controls Magnet PS FY12 | 302d | 2011-07-01 A | 2012-09-17 A | 1532060c FS-120d | 100% |  |  | SCIENTIST [77.42 h] | 5,430.86 | 5,430.86 | 0 | 5466.6262 | CHUDAKOV | 1 | 1 | D | S | EUGENE C | ST | 11-006 | 11-026 | 12-001 | 12-021F |  |  |  |  |  |  |  |  |  |  |  |  |  |  |  |
| 1532060d |  | Plan Experiment Controls HV FY11 | 174d | 2011-07-01 A | 2012-03-19 A | 9-110M FS+120d | 100% | 2011-07-01 | 2012-03-16 | SCIENTIST [61.94 h] | 4,323.92 | 4,335.3 | 0 | 4238.5542 | CHUDAKOV | 1 | 1 | D | S | EUGENE C | ST | 11-006 | 11-026 | 12-001 | 12-021F |  |  |  |  |  |  |  |  |  |  |  |  |  |  |  |
| 1532060da |  | Plan Experiment Controls HV FY12 | 175d | 2011-07-01 A | 2012-03-19 A | 1532060d FS-120d | 100% |  |  | SCIENTIST [58.06 h] | 4,053.33 | 4,053.33 | 0 | 4099.6166 | CHUDAKOV | 1 | 1 | D | S | EUGENE C | ST | 11-006 | 11-026 | 12-001 | 12-021F |  |  |  |  |  |  |  |  |  |  |  |  |  |  |  |
| 1532060f |  | Plan Experiment Controls LV FY11 | 175d | 2011-07-01 A | 2012-03-19 A | 9-110M FS+120d | 100% |  |  | SCIENTIST [82.58 h] | 5,765.14 | 5,765.14 | 0 | 5650.9494 | CHUDAKOV | 1 | 1 | D | S | EUGENE C | ST | 11-006 | 11-026 | 12-001 | 12-021F |  |  |  |  |  |  |  |  |  |  |  |  |  |  |  |
| 1532060fa |  | Plan Experiment Controls LV FY12 | 175d | 2011-07-01 A | 2012-03-19 A | 1532060f FS-120d | 100% |  |  | SCIENTIST [77.42 h] | 5,404.9 | 5,404.9 | 0 | 5466.6262 | CHUDAKOV | 1 | 1 | D | S | EUGENE C | ST | 11-006 | 11-026 | 12-001 | 12-021F |  |  |  |  |  |  |  |  |  |  |  |  |  |  |  |
| 1532060j |  | Plan Experiment Controls Temperature FY11 | 392d | 2011-07-01 A | 2013-03-11 A | 9-110M FS+120d | 100% | 2011-07-01 | 2013-02-01 | SCIENTIST [82.58 h] | 5,839.98 | 5,850.58 | 0 | 5650.9494 | CHUDAKOV | 1 | 1 | D | S | EUGENE C | ST | 11-006 | 11-026 | 12-001 | 12-021F |  | XX |  |  |  |  |  |  |  |  |  |  |  |  |  |
| 1532060ja |  | Plan Experiment Controls Temperature FY12 | 392d | 2011-07-01 A | 2013-03-11 A | 1532060j FS-120d | 100% | 2011-07-01 | 2013-02-01 | SCIENTIST [77.42 h] | 5,475.07 | 5,485 | 0 | 5466.6262 | CHUDAKOV | 1 | 1 | D | S | EUGENE C | ST | 11-006 | 11-026 | 12-001 | 12-021F |  | XX |  |  |  |  |  |  |  |  |  |  |  |  |  |
| 1532060k |  | Plan Experiment Controls Target FY11 | 410d | 2011-07-01 A | 2013-04-15 A | 9-110M FS+120d | 100% | 2011-07-01 | 2013-02-28 | SCIENTIST [103.23 h] | 7,310.03 | 7,345.29 | 0 | 7064.0289 | CHUDAKOV | 1 | 1 | D | S | EUGENE C | ST | 11-006 | 11-026 | 12-001 | 12-021F |  | XX |  |  |  |  |  |  |  |  |  |  |  |  |  |
| 1532060ka |  | Plan Experiment Controls Target FY12 | 410d | 2011-07-01 A | 2013-04-15 A | 1532060k FS-140d | 100% | 2011-07-01 | 2013-02-28 | SCIENTIST [96.77 h] | 6,852.57 | 6,866.92 | 0 | 6832.9297 | CHUDAKOV | 1 | 1 | D | S | EUGENE C | ST | 11-006 | 11-026 | 12-001 | 12-021F |  | XX |  |  |  |  |  |  |  |  |  |  |  |  |  |
| 1532060n |  | Plan Experiment Controls Interface with DAQ FY11 | 390d | 2011-07-01 A | 2013-07-15 A | 9-110M FS+120d | 100% | 2011-07-01 | 2013-01-30 | SCIENTIST [61.94 h] | 4,379.65 | 4,416.46 | 3178.91565 | 4238.5542 | CHUDAKOV | 1 | 1 | D | S | EUGENE C | ST | 11-006 | 11-026 | 12-001 |  |  | XX |  |  |  |  |  |  |  |  |  |  |  |  |  |
| 1532060na |  | Plan Experiment Controls Interface with DAQ FY12 | 390d | 2011-07-01 A | 2013-07-15 A | 1532060n FS-120d | 100% | 2011-07-01 | 2013-01-30 | SCIENTIST [58.06 h] | 4,105.31 | 4,133.76 | 3074.71245 | 4099.6166 | CHUDAKOV | 1 | 1 | D | S | EUGENE C | ST | 11-006 | 11-026 | 12-001 |  |  | XX |  |  |  |  |  |  |  |  |  |  |  |  |  |
| 1532012E |  | FY12 Travel (ONLINE COMP) FY12 | 247d | 2011-10-03 A | 2012-09-28 A | 1532011E | 100% |  |  | TRAVEL | 1,541.63 |  | 0 | 1541.63 | CHUDAKOV | 1 | 1 | D | E | EUGENE C |  | 11-006 | 11-026 |  |  |  |  | 8.06451612 | 91.93548387 | 100 | 100 | 07-024 | 12-053 |  |  |  |  |  |  |  |
| 1532045b |  | Plan Archiving Controls | 258d | 2011-10-03 A | 2012-10-15 A | 9-120M | 100% |  |  | SCIENTIST [200 h] | 14,141.19 | 14,141.19 | 0 | 14122 | CHUDAKOV | 1 | 1 | D | S | EUGENE C | ST | 11-006 | 11-026 |  | 12-021F |  |  |  |  |  |  |  |  |  |  |  |  |  |  |  |
| 1532040 |  | Plan Alarm Sys | 285d | 2011-12-01 A | 2013-04-15 A | 9-120M | 100% | 2011-12-01 | 2013-01-30 | SCIENTIST [220 h]; CONTRB UNIV LBR [220 h] | 15,671.41 | 15,726.62 | 0 | 15534.2 | CHUDAKOV | 1 | 1 | D | S | EUGENE C | ST | 11-006 | 11-026 |  | 12-021F | 12-054F | XX |  |  |  |  |  |  |  |  |  |  |  |  |  |
| 1532045 |  | Plan Archiving DAQ Configuration | 13d | 2011-12-01 A | 2011-12-19 A | 9-120M | 100% |  |  | SCIENTIST [120 h] | 8,473.2 | 8,473.2 | 0 | 8473.2 | CHUDAKOV | 1 | 1 | D | S | EUGENE C | ST | 11-006 | 11-026 |  | 12-021F |  |  |  |  |  |  |  |  |  |  |  |  |  |  |  |
| 1532055 |  | Plan Storage Mngmnt | 10d | 2012-01-07 A | 2012-01-23 A | 9-120M FS+82d | 100% | 2012-01-09 | 2012-01-23 | COMP SCIENT [352 h]; SCIENTIST [100 h] | 30,159.24 | 30,159.24 | 0 | 30159.24 | CHUDAKOV | 1 | 1 | D | S | EUGENE C | ST | 11-006 | 11-026 |  | 12-021F |  |  |  |  |  |  |  |  |  |  |  |  |  |  |  |
| 1532005 |  | Proc Trigger Testbed Electrnc's PR | 264d | 2012-01-09 A | 2013-02-11 A | 9-120M FS+58d | 100% | 2012-01-09 | 2013-01-30 | SCIENTIST [120 h] | 8,554 | 8,559.56 | 0 | 8473.2 | CHUDAKOV | 1 | 1 | D | H | EUGENE C |  | 11-006 | 11-026 |  | 12-021F |  | XX |  |  |  |  | 07-024 |  | 07-027 | 531 |  |  |  |  |  |
| 1532065 |  | Trigger Board Initialization FY11 | 200d | 2012-02-01 A | 2012-11-12 A | 9-120M FS+60d, 9-110M FS+184d | 100% |  |  | SCIENTIST [134.92 h]; COMP SCIENT [51.89 h] | 12,995.58 | 12,995.58 | 0 | 12532.2607 | CHUDAKOV | 1 | 1 | D | S | EUGENE C | ST | 11-006 | 11-026 | 12-001 | 12-021F | 12-054F |  |  |  |  |  |  |  |  |  |  |  |  |  |  |
| 1532065a |  | Trigger Board Initialization FY12 Part A (Hall D grp and CODA grp) | 223d | 2012-02-01 A | 2013-08-30 A | 1532065 FS-250d | 100% | 2012-02-01 | 2012-12-17 | COMP SCIENT [63.24 h]; SCIENTIST [164.43 h] | 15,881.8 | 16,048.6 | 7092.094995 | 15760.2111 | CHUDAKOV | 1 | 1 | D | S | EUGENE C | ST | 11-006 | 11-026 | 12-001 | 12-021 | 12-054F | XX |  |  |  |  |  |  |  |  |  |  |  |  |  |
| 1532065b |  | Trigger Board Initialization FY12 Part B (Hall D grp and CODA grp) | 223d | 2012-02-01 A | 2013-08-30 A | 1532065a FS-170d | 100% | 2012-02-01 | 2012-12-17 | COMP SCIENT [60.55 h]; SCIENTIST [157.42 h] | 15,205.14 | 15,364.81 | 6789.92274 | 15088.7172 | CHUDAKOV | 1 | 1 | D | S | EUGENE C | ST | 11-006 | 11-026 | 12-001 | 12-021 | 12-054F | XX |  |  |  |  |  |  |  |  |  |  |  |  |  |
| 1532067 |  | Level 1 Verification/debugging FY11 | 260d | 2012-02-01 A | 2013-06-17 A | 9-120M FS+65d, 9-110M FS+184d | 100% | 2012-02-01 | 2013-02-15 | SCIENTIST [71.11 h]; COMP SCIENT [71.11 h] | 9,795.34 | 9,844.31 | 0 | 9387.9422 | CHUDAKOV | 1 | 1 | D | S | EUGENE C | ST | 11-006 | 11-026 | 12-001 | 12-021F |  | XX |  |  |  |  |  |  |  |  |  |  |  |  |  |
| 1532067a |  | Level 1 Trigger Verification/debugging FY12 Part A | 260d | 2012-02-01 A | 2013-06-17 A | 1532067 FS-250d | 100% | 2012-02-01 | 2013-02-15 | COMP SCIENT [86.67 h]; SCIENTIST [86.67 h] | 11,938.7 | 11,998.41 | 0 | 11807.0541 | CHUDAKOV | 1 | 1 | D | S | EUGENE C | ST | 11-006 | 11-026 | 12-001 | 12-021 |  | XX |  |  |  |  |  |  |  |  |  |  |  |  |  |
| 1532067b |  | Level 1 Trigger Verification/debugging FY12 Part B | 260d | 2012-02-01 A | 2013-06-17 A | 1532067a FS-160d | 100% | 2012-02-01 | 2013-02-15 | COMP SCIENT [84.4 h]; SCIENTIST [84.4 h] | 11,626.02 | 11,684.15 | 0 | 11497.812 | CHUDAKOV | 1 | 1 | D | S | EUGENE C | ST | 11-006 | 11-026 | 12-001 | 12-021 |  | XX |  |  |  |  |  |  |  |  |  |  |  |  |  |
| 1532105g |  | Write Experiment Control Motors FY12 | 355d | 2012-04-02 A | 2013-08-30 A | 1532060ga FS+10d | 100% |  |  | SCIENTIST [184.73 h]; CONTRB UNIV LBR [92.36 h] | 13,310.73 | 13,310.69 | 7174.081915 | 13043.7853 | CHUDAKOV | 1 | 1 | D | S | EUGENE C | ST | 11-006 | 11-026 |  | 12-021 |  |  |  |  |  |  |  | 12-053 |  |  |  |  |  |  |  |
| 1532105ga |  | Write Experiment Control Motors FY13 | 355d | 2012-04-02 A | 2013-08-30 A | 1532105g FS-235d | 100% |  |  | CONTRB UNIV LBR [67.64 h]; SCIENTIST [135.27 h] | 9,746.89 | 9,746.89 | 5420.67471 | 9855.7722 | CHUDAKOV | 1 | 1 | D | S | EUGENE C | ST | 11-006 | 11-026 |  | 12-021 |  |  |  |  |  |  |  | 12-053 |  |  |  |  |  |  |  |
| 1532007 |  | Proc Trigger Testbed Electrnc's (coordinate with Hovanes) Part A | 292d | 2012-07-02 A | 2013-01-14 A | 1532005 FS-110d | 100% | 2012-07-02 | 2013-08-30 | PROCUREMENT<$50K 60 | 24,765.6 |  | 0 | 24765.6 | CHUDAKOV | 1 | 1 | D | D | EUGENE C |  | 11-006 | 11-026 |  | 12-021 |  |  |  |  |  |  | 07-024 |  | 07-027 | 531 | 0 | 24765.6 | 2476560 | 100 | 12-055 |
| 1532012Ea |  | FY12 Travel (ONLINE COMP) FY13 | 1d | 2012-09-28 A | 2012-09-28 A | 1532012E | 100% |  |  | TRAVEL | 6.42 |  | 0 | 6.42 | CHUDAKOV | 1 | 1 | D | E | EUGENE C |  | 11-006 | 11-026 |  |  |  |  |  |  |  |  | 07-024 | 12-053 |  |  |  |  |  |  |  |
| 1532007a |  | Proc Trigger Testbed Electrnc's (coordinate with Hovanes) Part B | 228d | 2012-10-01 A | 2013-05-20 A | 1532005 FS-110d | 100% | 2012-10-01 | 2013-08-30 | PROCUREMENT<$50K 60 | 47,467.4 |  | 0 | 47467.4 | CHUDAKOV | 1 | 1 | D | D | EUGENE C |  | 11-006 | 11-026 |  | 12-021 |  |  |  |  |  |  | 07-024 |  | 07-027 | 531 | 0 | 47467.4 | 4746740 | 100 | 12-055 |
| 1532013E |  | FY13 Travel (ONLINE COMP) | 248d | 2012-10-01 A | 2013-08-30 A | 1532012Ea | 100% | 2012-10-01 | 2013-09-30 | TRAVEL | 1,467.9 |  | 270.570762 | 1467.9 | CHUDAKOV | 1 | 1 | D | E | EUGENE C |  | 11-006 | 11-026 |  |  |  |  | 16.93548387 | 83.06451612 | 100 | 100 | 07-024 |  |  |  |  |  |  |  |  |
| 1532067c |  | Level 1 Trigger Verification/debugging FY13 | 248d | 2012-10-01 A | 2013-08-30 A | 1532067b FS-100d | 100% | 2012-10-01 | 2013-09-30 | SCIENTIST [113.81 h]; COMP SCIENT [113.81 h] | 15,998.28 | 15,998.28 | 2947.9946804 | 15998.2717 | CHUDAKOV | 1 | 1 | D | E | EUGENE C |  | 11-006 | 11-026 | 12-001 | 12-021 |  |  | 8.06451612 | 91.93548387 | 100 | 100 |  |  |  |  |  |  |  |  |  |

Notes:
- 1532035b: Steps: Study of existing systems (done); Concept development (done); Prototyping of the system (done); Testing of the prototype (done); Planning document (done)
- 1532035ba: Steps: Study of existing systems (done); Concept development (done); Prototyping of the system (done); Testing of the prototype (done); Planning document (done)
- 1532060g: Steps: Study of existing systems (done); Concept development (done); Prototyping of the system (done); Testing of the prototype (done); Planning document (done)
- 1532060ga: Steps: Study of existing systems (done); Concept development (done); Prototyping of the system (done); Testing of the prototype (done); Planning document (done)
- 1532060a: Steps: Identify applications which need control and monitoring (done); Study a few of most eligible frameworks and evaluate their applicability to Hall D systems. (done); Make a prototype application utilizing the most favorable display (done); Create the planning document in DocDB. (done)
- 1532060aa: Steps: Identify applications which need control and monitoring (done); Study a few of most eligible frameworks and evaluate their applicability to Hall D systems. (done); Make a prototype application utilizing the most favorable display (done); Create the planning document in DocDB. (done)
- 1532060h: Steps: Identify the hardware components in the drift chamber gas systems that need to be directly controlled (done); Determine the best framework for controlling different components of the gas system (done); Draft a plan for the control system based on the available gas system design (done); Write DocDB Document (done)
- 1532060ha: Steps: Identify the hardware components in the drift chamber gas systems that need to be directly controlled (done); Determine the best framework for controlling different components of the gas system (done); Draft a plan for the control system based on the available gas system design (done); Write DocDB Document (done)
- 1532045a: Steps: Determine archiving requirements (done); Design archiving system (done); Test archiving concepts (done); Planning document in DocDB (done)
- 1532060: Steps: Design a directory structure and a makefile scheme. (done); Create an EPICS IOC application and compile the libraries and executables within that directory scheme. (done); Study the possibility and practicality of code management system for PLC programs and HMIs. (done); Create a small PLC-based test application, interface it with PLC and test it. (done); Create a small Labview program and interface it with EPICS and evaluate the reliability of such a combined system. (done); Incorporate the aforementioned sample applications into AFECS framework. (done); Define guidelines for most efficient interface between different types of control systems. (done); Create the planning document in DocDB. (done)
- 1532060p: Steps: Design a directory structure and a makefile scheme. (done); Create an EPICS IOC application and compile the libraries and executables within that directory scheme. (done); Study the possibility and practicality of code management system for PLC programs and HMIs. (done); Create a small PLC-based test application, interface it with PLC and test it. (done); Create a small Labview program and interface it with EPICS and evaluate the reliability of such a combined system. (done); Incorporate the aforementioned sample applications into AFECS framework. (done); Define guidelines for most efficient interface between different types of control systems. (done); Create the planning document in DocDB. (done)
- 1532025: Steps: Determine format that front-end configurations will be kept in (XML files, Database, ...) (done); How the front end will interface to the translation table used in offline (done); Authentication/configuration integrity assurance system (done); How users will switch between configurations (done); Map board layout in crates with expected bandwidth for each crate (done); Planning document in DocDB (done)
- 1532025a: Steps: Determine format that front-end configurations will be kept in (XML files, Database, ...) (done); How the front end will interface to the translation table used in offline (done); Authentication/configuration integrity assurance system (done); How users will switch between configurations (done); Map board layout in crates with expected bandwidth for each crate (done); Planning document in DocDB (done)
- 1532030: Steps: For plan for where and how often disentangling will occur (EB, L3 farm, offline, ¿?) (done); CPU/memory/bandwidth resources (done); Proposal for code structure (done); Translation table (done); Planning document in DocDB (done)
- 1532030a: Steps: Decide Language Policy (including preferred languages) (done); Establish directory structure in repository/disk (done); Decide on access restriction policy (repository and disk) and how it is implemented (done); Planning document in DocDB (done)
- 1532030aa: Steps: Decide Language Policy (including preferred languages) (done); Establish directory structure in repository/disk (done); Decide on access restriction policy (repository and disk) and how it is implemented (done); Planning document in DocDB (done)
- 1532030b: Steps: Remote access plan (done); List of suggested customization for Hall-D (done); Links to DAQ Group documentation on RC in Hall-D documentation system (done); Planning document in DocDB (done)
- 1532030ba: Steps: Remote access plan (done); List of suggested customization for Hall-D (done); Links to DAQ Group documentation on RC in Hall-D documentation system (done); Planning document in DocDB (done)
- 1532030c: Steps: Decide on versioning system, host location, and access mechanisms (done); Plan for integration with offline (done); Choose build system (autoconf, make, scons,¿?) and form initial plan for implementation (done); Source code directory structure (done); Planning document in DocDB (done)
- 1532030ca: Steps: Decide on versioning system, host location, and access mechanisms (done); Plan for integration with offline (done); Choose build system (autoconf, make, scons,¿?) and form initial plan for implementation (done); Source code directory structure (done); Planning document in DocDB (done)
- 1532030d: Steps: For plan for where and how often disentangling will occur (EB, L3 farm, offline, ¿?) (done); CPU/memory/bandwidth resources (done); Proposal for code structure (done); Translation table (done); Planning document in DocDB (done)
- 1532035: Steps: Develop overall monitoring, archiving and display philosophy and determine requirements (done); Determine overall database requirements (done); Determine computer and network monitoring requirements (done); Determine farm management requirements (done); Evaluate use of IRMIS for controls configuration database (done); Test concepts as needed (done); Planning document in DocDB (done)
- 1532035a: Steps: Determine monitoring, display, archive and alarm requirements (done); Design monitoring system (done); Test concepts (done); Planning document in DocDB (done)
- 1532035aa: Steps: Determine monitoring, display, archive and alarm requirements (done); Design monitoring system (done); Test concepts (done); Planning document in DocDB (done)
- 1532035c: Steps: Evaluate remote monitoring requirements (done); Evaluate security issues (done); Design remote monitoring system (done); Test remote monitoring and security concepts (done); Planning document in DocDB (done)
- 1532035ca: Steps: Evaluate remote monitoring requirements (done); Evaluate security issues (done); Design remote monitoring system (done); Test remote monitoring and security concepts (done); Planning document in DocDB (done)
- 1532035d: Steps: Determine monitoring, display, archive and alarm requirements (done); Design hardware monitoring system (done); Test hardware monitoring concepts (done); Planning document in DocDB (done)
- 1532035da: Steps: Determine monitoring, display, archive and alarm requirements (done); Design hardware monitoring system (done); Test hardware monitoring concepts (done); Planning document in DocDB (done)
- 1532035f: Steps: Evaluate monitoring, display, archive and alarm requirements (done); Design monitoring system (done); Test concepts (done); Planning document in DocDB (done)
- 1532035fa: Steps: Evaluate monitoring, display, archive and alarm requirements (done); Design monitoring system (done); Test concepts (done); Planning document in DocDB (done)
- 1532035g: Steps: Determine monitoring, display, archive and alarm requirements (done); Design monitoring system (done); Test concepts (done); Planning document in DocDB (done)
- 1532035ga: Steps: Determine monitoring, display, archive and alarm requirements (done); Design monitoring system (done); Test concepts (done); Planning document in DocDB (done)
- 1532035h: Steps: Develop overall monitoring, archiving and display philosophy and determine requirements (done); Determine overall database requirements (done); Determine computer and network monitoring requirements (done); Determine farm management requirements (done); Evaluate use of IRMIS for controls configuration database (done); Test concepts as needed (done); Planning document in DocDB (done)
- 1532050: Steps: Create list of requirements including list of features, data format, and I/O (done); Decide on framework/drawing package (done)
- 1532050a: Steps: Create list of requirements including list of features, data format, and I/O (done); Decide on framework/drawing package (done)
- 1532060b: Steps: Study existing backup/restore options for EPICS-based applications. (done); Design a framework for configuring backing and restoring the large number of EPICS PVs. (done); Create a prototype EPICS application requiring backing and restoring variables, and thoroughly test (done); Study how PLC-based applications restore the value of its control tags, and how we could configure the applications (done); Design a framework for configuring backing and restoring the large number of tags. (done); Create a prototype PLC application requiring backing and restoring variables, and thoroughly test (done); Study the needs for backup/restore for other type of control systems used in the hall, such as LabView. (done); Create the planning document in DocDB. (done)
- 1532060ba: Steps: Study existing backup/restore options for EPICS-based applications. (done); Design a framework for configuring backing and restoring the large number of EPICS PVs. (done); Create a prototype EPICS application requiring backing and restoring variables, and thoroughly test (done); Study how PLC-based applications restore the value of its control tags, and how we could configure the applications (done); Design a framework for configuring backing and restoring the large number of tags. (done); Create a prototype PLC application requiring backing and restoring variables, and thoroughly test (done); Study the needs for backup/restore for other type of control systems used in the hall, such as LabView. (done); Create the planning document in DocDB. (done)
- 1532060c: Steps: Study power supplies for four magnets in terms of hardware and the available software (done); Develop general plan for controlling each magnet power supply (done); Write DocDB Document (done)
- 1532060ca: Steps: Study power supplies for four magnets in terms of hardware and the available software (done); Develop general plan for controlling each magnet power supply (done); Write DocDB Document (done)
- 1532060d: Steps: Study available options for CAEN SY1527 mainframe EPICS drivers with A1535N, A1535SN and A1535P (done); Obtain one CAN-bus/Ethernet bridge and the software used by IU and evaluate the work required for implementing (done); Determine what set of HV-related parameters for CAEN and CAN-bas systems need to be accessed (done); Draft a set of HV GUIs (done); Understand how HV alarms should be included into common alarm handling system (done); Plan integration of HV parameters values into Hall D archiving scheme (done); Write DocDB Document (done)
- 1532060da: Steps: Study available options for CAEN SY1527 mainframe EPICS drivers with A1535N, A1535SN and A1535P (done); Obtain one CAN-bus/Ethernet bridge and the software used by IU and evaluate the work required for implementing (done); Determine what set of HV-related parameters for CAEN and CAN-bas systems need to be accessed (done); Draft a set of HV GUIs (done); Understand how HV alarms should be included into common alarm handling system (done); Plan integration of HV parameters values into Hall D archiving scheme (done); Write DocDB Document (done)
- 1532060f: Steps: Identify and study hardware that provides/distributes preamp low voltages and SiPM bias voltages (done); Search for the best options for LV control system fitting Hall D needs (done); Draft a set of HV GUIs (done); Write DocDB Document (done)
- 1532060fa: Steps: Identify and study hardware that provides/distributes preamp low voltages and SiPM bias voltages (done); Search for the best options for LV control system fitting Hall D needs (done); Draft a set of HV GUIs (done); Write DocDB Document (done)
- 1532060j: Steps: Identify control points for various Hall D systems requiring temperature control (done); Determine the hardware required for temperature control (done); Design control system based on available description of the problems (done); Write DocDB Document (done)
- 1532060ja: Steps: Identify control points for various Hall D systems requiring temperature control (done); Determine the hardware required for temperature control (done); Design control system based on available description of the problems (done); Write DocDB Document (done)
- 1532060k: Steps: Communicate with the Jlab target group and determine the scope of the work and the control points (done); Decide on the hardware required and the framework to be used for the target controls (done); Design a work plan for creating a control system (done); Write DocDB Document (done)
- 1532060ka: Steps: Communicate with the Jlab target group and determine the scope of the work and the control points (done); Decide on the hardware required and the framework to be used for the target controls (done); Design a work plan for creating a control system (done); Write DocDB Document (done)
- 1532060n: Steps: Create initial list of controls/monitoring variables DAQ should be aware of (done); Plan for storing configurations in repository and on disk (done); Planning document in DocDB (done)
- 1532060na: Steps: Create initial list of controls/monitoring variables DAQ should be aware of (done); Plan for storing configurations in repository and on disk (done); Planning document in DocDB (done)
- 1532045b: Steps: Determine archiving requirements (done); Evaluate existing controls archiving packages (done); Choose and test archiving package (done); Planning document in DocDB (done)
- 1532040: Steps: Determine alarm system requirements (done); Evaluate existing alarm packages (done); Choose and test alarm package (done); Planning document in DocDB (done)
- 1532045: Steps: Determine archiving requirements (done); Design archiving system (done); Test archiving concepts (done); Planning document in DocDB (done)
- 1532055: Steps: Decide on hardware and filesystem (done); Detailed plan for connection to computing center (done); Reading and writing bandwidth requirements from disk (done); Slow controls archiving to tape silo (done); Planning document in DocDB (done)
- 1532065: Steps: Prototype Level-1 (L1) Control (done); Prototype Level-1 Client Process on ROC (done); Prototype Run Configuration Database (done); Prototype Interface between the L1 Control and Run Control and DB (done); Expert GUI Development (done); Check Prototype Performance (done); Final Implementation (done)
- 1532065a: Steps: Prototype Level-1 (L1) Control (done); Prototype Level-1 Client Process on ROC (done); Prototype Run Configuration Database (done); Prototype Interface between the L1 Control and Run Control and DB (done); Expert GUI Development (done); Check Prototype Performance (done); Final Implementation (done)
- 1532065b: Steps: Prototype Level-1 (L1) Control (done); Prototype Level-1 Client Process on ROC (done); Prototype Run Configuration Database (done); Prototype Interface between the L1 Control and Run Control and DB (done); Expert GUI Development (done); Check Prototype Performance (done); Final Implementation (done)
- 1532067: Steps: Software Development for the Play Back Implementation (done); Interface with Geant and Bitwise Simulation (done); Software Development for the Trigger Event Analyzer (done); Check Performance (done)
- 1532067a: Steps: Software Development for the Play Back Implementation (done); Interface with Geant and Bitwise Simulation (done); Software Development for the Trigger Event Analyzer (done); Check Performance (done)
- 1532067b: Steps: Software Development for the Play Back Implementation (done); Interface with Geant and Bitwise Simulation (done); Software Development for the Trigger Event Analyzer (done); Check Performance (done)
- 1532105g: Steps: Install EPICS support for motion controllers (done); Applicaton for collimator motion (done); Applicaton for PS converter motion (done); Applicaton for harp scans (done); Create control GUIs (done)
- 1532105ga: Steps: Install EPICS support for motion controllers (done); Applicaton for collimator motion (done); Applicaton for PS converter motion (done); Applicaton for harp scans (done); Create control GUIs (done)

| ID | Activity | Duration | Start | Finish | Predecessors | Complete | Remaining | Planned start | Planned finish | Total float | Free float | Calendar | Resources | Cost | Actual cost | Calculated Remaining Total Cost | MONTHLY EV COST | RESP - Responsibility | STRT%COMP for CM EVM | FNSH%COMP for CM EVM | HALL D Related Milestones | EVMS Reporting Codes | CAM RESPONSIBLE | Activities with Steps | CR 11-006 | CR 11-026 | CR 12-021 | CR 12-053 | CR 07-024 | CR 07-027 | 12 GEV MAJOR PROCUREMENT CATAGORY | CR 12-054 | MARCH!!! | Inter Project Link (IPL) | Remaining Material Cost Based on % Compl | Claimed Material Cost Based on % Complet | Initial Claimed Material Calc | Claimed Material Divider | CR 12-001 | ReBaseline Actuals Adjustment | LOE Divider | LOE Multiplier | Original Activity ID Rebaseline | PRIOR MONTH EV COST | CR 13-007 | BOE Expenses | CR 13-015 | Post Rebaseline | Obligated Prior to Rebaseline | BOE Labor | CR 14-001 | CR 12-040 |
| --- | --- | --- | --- | --- | --- | --- | --- | --- | --- | --- | --- | --- | --- | --- | --- | --- | --- | --- | --- | --- | --- | --- | --- | --- | --- | --- | --- | --- | --- | --- | --- | --- | --- | --- | --- | --- | --- | --- | --- | --- | --- | --- | --- | --- | --- | --- | --- | --- | --- | --- | --- | --- |
| 1532105 | Write Experiment Control Framework (FY13 @ 1532105s) | 306d | 2012-10-01 A | 2013-07-15 A | 1532060p FS-20d, 1531240 | 100% |  | 2012-10-01 | 2013-12-30 |  |  |  | SCIENTIST [147.78 h] | 10,832.24 | 10,767.25 | 4173.89832 | 10434.7458 | CHUDAKOV | 1 | 1 | D | S | EUGENE C | ST | 11-006 | 11-026 | 12-021 | 12-053 |  |  |  |  |  |  |  |  |  |  |  |  |  |  |  |  |  |  |  |  |  |  |  |  |
| 1532105s | Write Experiment Control Framework FY13 (FY12 @ 1532105) | 300d | 2012-10-01 A | 2013-08-30 A | 1532105 FS-350d | 100% |  | 2012-10-01 | 2013-12-13 |  |  |  | SCIENTIST [108.22 h] | 7,928.43 | 7,884.91 | 3153.96368 | 7884.9092 | CHUDAKOV | 1 | 1 | D | S | EUGENE C | ST | 11-006 | 11-026 | 12-021 | 12-053 |  |  |  |  |  |  |  |  |  |  |  |  |  |  |  |  |  |  |  |  |  |  |  |  |
| 1532010 | Proc L3 Farm infrastructure PR | 17d | 2013-01-07 A | 2013-01-21 A | 9-130M FS+70d, 1233040M, 9-120M FS+185d | 100% |  | 2013-02-01 | 2013-02-26 |  |  |  | COMP SCIENT [80 h]; SCIENTIST [80 h] | 11,245.6 | 11,245.6 | 0 | 10898.4 | CHUDAKOV | 1 | 1 | D | H | EUGENE C |  | 11-006 | 11-026 | 12-021F |  | 07-024 | 07-027 | 531 | 12-054F | XX |  |  |  |  |  |  |  |  |  |  |  |  |  |  |  |  |  |  |  |
| 1532080 | Write Monitoring Framework FY12 | 221d | 2013-05-01 A | 2013-08-30 A | 9-120M, 1532035h | 100% |  | 2013-06-03 | 2014-04-23 |  |  |  | SCIENTIST [128 h]; CONTRB UNIV LBR [120 h] | 9,510.17 | 9,326.08 | 3434.4704 | 9038.08 | CHUDAKOV | 1 | 1 | D | S | EUGENE C | ST | 11-006 | 11-026 | 12-021 |  |  |  |  | 12-054F |  |  |  |  |  |  |  |  |  |  |  |  |  |  |  |  |  |  |  |  |
| 1532082 | Write Monitoring Framework FY13 | 221d | 2013-05-01 A | 2013-08-30 A | 1532080 FS-221d, 9-130M | 100% |  | 2013-06-03 | 2014-04-23 |  |  |  | SCIENTIST [108.31 h]; CONTRB UNIV LBR [101.54 h] | 8,047.21 | 7,891.44 | 3543.9104 | 7891.443066 | CHUDAKOV | 1 | 1 | D | S | EUGENE C | ST | 11-006 | 11-026 | 12-021 |  |  |  |  | 12-054 |  |  |  |  |  |  |  |  |  |  |  |  |  |  |  |  |  |  |  |  |
| 1532105d | Write Experiment Control HV FY12 | 178d | 2013-05-01 A | 2013-08-30 A | 9-130M FS+152d, 1532060da FS+85d | 100% |  | 2013-06-03 | 2014-02-21 |  |  |  | SCIENTIST [158.12 h]; CONTRB UNIV LBR [112.94 h] | 11,714.35 | 11,520.62 | 8373.6399 | 11164.8532 | CHUDAKOV | 1 | 1 | D | S | EUGENE C | ST | 11-006 | 11-026 | 12-021 | 12-053 |  |  |  |  |  |  |  |  |  |  |  |  |  |  |  |  |  |  |  |  |  |  |  |  |
| 1532105da | Write Experiment Control HV FY13 | 178d | 2013-05-01 A | 2013-08-30 A | 9-130M FS+152d, 1532105d FS-220d | 100% |  | 2013-06-03 | 2014-02-21 |  |  |  | SCIENTIST [289.88 h]; CONTRB UNIV LBR [207.06 h] | 21,475.81 | 21,120.66 | 15840.4926 | 21120.6568 | CHUDAKOV | 1 | 1 | D | S | EUGENE C | ST | 11-006 | 11-026 | 12-021 | 12-053 |  |  |  |  |  |  |  |  |  |  |  |  |  |  |  |  |  |  |  |  |  |  |  |  |
| 1532105f | Write Experiment Control LV FY12 | 178d | 2013-05-01 A | 2013-08-30 A | 9-130M FS+152d, 1532060fa FS+85d | 100% |  | 2013-06-03 | 2014-02-21 |  |  |  | SCIENTIST [135.53 h] | 10,040.76 | 9,874.72 | 8134.307305 | 9569.7733 | CHUDAKOV | 1 | 1 | D | S | EUGENE C | ST | 11-006 | 11-026 | 12-021 | 12-053 |  |  |  |  |  |  |  |  |  |  |  |  |  |  |  |  |  |  |  |  |  |  |  |  |
| 1532105fa | Write Experiment Control LV FY13 | 178d | 2013-05-01 A | 2013-08-30 A | 9-130M FS+152d, 1532105f FS-220d | 100% |  | 2013-06-03 | 2014-02-21 |  |  |  | SCIENTIST [248.47 h] | 18,407.94 | 18,103.52 | 15387.99557 | 18103.5242 | CHUDAKOV | 1 | 1 | D | S | EUGENE C | ST | 11-006 | 11-026 | 12-021 | 12-053 |  |  |  |  |  |  |  |  |  |  |  |  |  |  |  |  |  |  |  |  |  |  |  |  |
| 1532075c | Write DAQ Software Code Management | 166d | 2013-05-03 A | 2013-05-20 A | 9-130M FS+164d, 1532030ca | 100% |  | 2013-06-03 | 2014-02-04 |  |  |  | SCIENTIST [128 h] | 9,472.77 | 9,326.08 | 0 | 9326.08 | CHUDAKOV | 1 | 1 | D | H | EUGENE C |  | 11-006 | 11-026 | 12-021 |  |  |  |  | 12-054F |  | IPL |  |  |  |  |  |  |  |  |  |  |  |  |  |  |  |  |  |  |
| 1532080b | Write Monitoring Histograms FY12 | 84d | 2013-06-01 A | 2013-08-30 A | 9-130M FS+110d, 1532035ba | 100% |  | 2013-07-01 | 2013-10-28 |  |  |  | SCIENTIST [73.31 h]; CONTRB UNIV LBR [122.18 h] | 5,381.86 | 5,341.37 | 3519.964988 | 5176.4191 | CHUDAKOV | 1 | 1 | D | S | EUGENE C | ST | 11-006 | 11-026 | 12-021 | 12-053 |  |  |  | 12-054F |  |  |  |  |  |  |  |  |  |  |  |  |  |  |  |  |  |  |  |  |
| 1532080ba | Write Monitoring Histograms FY13 | 136d | 2013-06-01 A | 2013-08-30 A | 1532080b FS-120d | 100% |  | 2013-10-29 | 2014-05-20 |  |  |  | SCIENTIST [118.69 h]; CONTRB UNIV LBR [197.82 h] | 8,923.11 | 8,647.75 | 5880.472312 | 8647.7534 | CHUDAKOV | 1 | 1 | D | S | EUGENE C | ST | 11-006 | 11-026 | 12-021 | 12-053 |  |  |  | 12-054F |  |  |  |  |  |  |  |  |  |  |  |  |  |  |  |  |  |  |  |  |
| 1532075 | Write DAQ Software Event Unblocking | 166d | 2013-07-01 A | 2013-07-15 A | 1532030d, 9-130M FS+164d | 100% |  | 2013-08-01 | 2014-04-04 |  |  |  | SCIENTIST [352 h] | 26,256.74 | 25,646.72 | 25646.72 | 25646.72 | CHUDAKOV | 1 | 1 | D | S | EUGENE C | ST | 11-006 | 11-026 | 12-021 |  |  |  |  | 12-054F |  | IPL |  |  |  |  |  |  |  |  |  |  |  |  |  |  |  |  |  |  |
| 1532080c | Write Monitoring Remote | 95d | 2013-07-01 A | 2013-07-15 A | 9-130M FS+164d, 1532035ca | 100% |  | 2013-09-13 | 2014-02-05 |  |  |  | SCIENTIST [128 h]; CONTRB UNIV LBR [320 h] | 9,585.53 | 9,326.08 | 9326.08 | 9326.08 | CHUDAKOV | 1 | 1 | D | S | EUGENE C | ST | 11-006 | 11-026 | 12-021 |  |  |  |  | 12-054F |  |  |  |  |  |  |  |  |  |  |  |  |  |  |  |  |  |  |  |  |
| 1532105n | Write Experiment Control Interface with DAQ FY12 | 143d | 2013-07-01 A | 2013-07-15 A | 1532060na FS+54d | 100% |  | 2013-11-01 | 2014-06-04 |  |  |  | SCIENTIST [73.89 h] | 5,555.05 | 5,383.63 | 5217.3729 | 5217.3729 | CHUDAKOV | 1 | 1 | D | S | EUGENE C | ST | 11-006 | 11-026 | 12-021 | 12-053 |  |  |  |  |  |  |  |  |  |  |  |  |  |  |  |  |  |  |  |  |  |  |  |  |
| 1532105na | Write Experiment Control Interface with DAQ FY13 | 143d | 2013-07-01 A | 2013-07-15 A | 1532105n FS-221d | 100% |  | 2013-08-01 | 2014-03-04 |  |  |  | SCIENTIST [54.11 h] | 4,031.12 | 3,942.45 | 3942.4546 | 3942.4546 | CHUDAKOV | 1 | 1 | D | S | EUGENE C | ST | 11-006 | 11-026 | 12-021 | 12-053 |  |  |  |  |  |  |  |  |  |  |  |  |  |  |  |  |  |  |  |  |  |  |  |  |
| 1532015 | Install L3 Farm infrastructure | 39d | 2013-07-02 A | 2013-08-30 A | 1532010a FS-100d | 100% |  | 2014-01-02 | 2014-02-27 |  |  |  | COMP SCIENT [118.44 h]; SCIENTIST [39.48 h] | 11,243.51 | 11,027.47 | 22079.2 | 10896.0852 | CHUDAKOV | 1 | 1 | D | H | EUGENE C |  | 11-006 | 11-026 | 12-021 |  |  |  |  | 12-054 |  |  |  |  |  |  |  |  |  |  |  |  |  |  |  |  |  |  |  |  |
| 1532010a | Proc L3 Farm infrastructure Phase 1 | 101d | 2013-08-30 A | 2013-08-30 A | 9-130M FS+100d, 1532010 FS+40d | 100% |  | 2013-09-03 | 2014-02-03 |  |  |  | PROCUREMENT<$50K 60 | 13,414.7 |  | 13414.7 | 13414.7 | CHUDAKOV | 1 | 1 | D | D | EUGENE C |  | 11-006 | 11-026 | 12-021 |  | 07-024 | 07-027 | 531 | 12-054 |  |  | 0 | 13414.7 | 1341470 | 100 |  |  |  |  |  |  |  |  |  |  |  |  |  |  |
| 1532065c | Trigger Board Initialization FY13 (Hall D grp and CODA grp) | 109d | 2013-08-30 A | 2013-08-30 A | 1532065b | 100% |  | 2013-10-03 | 2014-03-18 |  |  |  | SCIENTIST [184.89 h]; COMP SCIENT [71.11 h] | 18,868.48 | 18,285.93 | 18285.937779 | 16810.91975 | CHUDAKOV | 1 | 1 | D | S | EUGENE C | ST | 11-006 | 11-026 | 12-021 |  |  |  |  | 12-054F |  |  |  |  |  |  | 12-001 |  |  |  |  |  |  |  |  |  |  |  |  |  |
| 1532070 | Write Front-End Software | 166d | 2013-08-30 A | 2013-08-30 A | 1532025a, 9-130M FS+164d | 100% |  | 2013-09-03 | 2014-05-06 |  |  |  | SCIENTIST [608 h] | 45,539.49 | 44,298.88 | 44298.88 | 44298.88 | CHUDAKOV | 1 | 1 | D | S | EUGENE C | ST | 11-006 | 11-026 | 12-021 |  |  |  |  |  |  |  |  |  |  |  |  |  |  |  |  |  |  |  |  |  |  |  |  |  |
| 1532075a | Write DAQ Software Scripts FY12 | 166d | 2013-08-30 A | 2013-08-30 A | 1532030aa, 9-120M FS+163d, 9-130M FS+164d | 100% |  | 2013-09-03 | 2014-05-06 |  |  |  | SCIENTIST [160 h] | 11,984.08 | 11,657.6 | 11297.6 | 11297.6 | CHUDAKOV | 1 | 1 | D | S | EUGENE C | ST | 11-006 | 11-026 | 12-021 |  |  |  |  | 12-054F |  | IPL |  |  |  |  |  |  |  |  |  |  |  |  |  |  |  |  |  |  |
| 1532075b | Write DAQ Software Run Control FY12 | 166d | 2013-08-30 A | 2013-08-30 A | 9-130M FS+164d, 1532030ba | 100% |  | 2013-09-03 | 2014-05-06 |  |  |  | SCIENTIST [124.51 h] | 9,325.86 | 9,071.8 | 8791.6511 | 8791.6511 | CHUDAKOV | 1 | 1 | D | S | EUGENE C | ST | 11-006 | 11-026 | 12-021 | 12-053 |  |  |  | 12-054F |  | IPL |  |  |  |  |  |  |  |  |  |  |  |  |  |  |  |  |  |  |
| 1532075ba | Write DAQ Software Run Control FY13 | 166d | 2013-08-30 A | 2013-08-30 A | 9-130M FS+164d, 1532075b FS-220d | 100% |  | 2013-09-03 | 2014-05-06 |  |  |  | SCIENTIST [131.49 h] | 9,848.66 | 9,580.36 | 9580.3614 | 9580.3614 | CHUDAKOV | 1 | 1 | D | S | EUGENE C | ST | 11-006 | 11-026 | 12-021 | 12-053 |  |  |  | 12-054F |  | IPL |  |  |  |  |  |  |  |  |  |  |  |  |  |  |  |  |  |  |
| 1532077 | Write DAQ Software Scripts FY13 | 166d | 2013-08-30 A | 2013-08-30 A | 9-130M FS+164d, 1532075a FS-220d | 100% |  | 2013-09-03 | 2014-05-06 |  |  |  | SCIENTIST [160 h] | 11,984.08 | 11,657.6 | 11657.6 | 11657.6 | CHUDAKOV | 1 | 1 | D | S | EUGENE C | ST | 11-006 | 11-026 | 12-021 |  |  |  |  | 12-054F |  | IPL |  |  |  |  |  |  |  |  |  |  |  |  |  |  |  |  |  |  |
| 1532080a | Write Monitoring Scalers | 121d | 2013-08-30 A | 2013-08-30 A | 9-130M FS+110d, 1532035aa FS+100d | 100% |  | 2013-09-03 | 2014-03-04 |  |  |  | SCIENTIST [192 h] | 14,360.93 | 13,989.12 | 13989.12 | 13989.12 | CHUDAKOV | 1 | 1 | D | S | EUGENE C | ST | 11-006 | 11-026 | 12-021 |  |  |  |  | 12-054F |  |  |  |  |  |  |  |  |  |  |  |  |  |  |  |  |  |  |  |  |
| 1532080d | Write Monitoring Hardware Status FY12 | 95d | 2013-08-30 A | 2013-08-30 A | 9-130M FS+164d, 1532035da | 100% |  | 2013-09-18 | 2014-02-10 |  |  |  | SCIENTIST [48.87 h] | 3,663.31 | 3,560.67 | 3450.7107 | 3450.7107 | CHUDAKOV | 1 | 1 | D | S | EUGENE C | ST | 11-006 | 11-026 | 12-021 | 12-053 |  |  |  | 12-054F |  |  |  |  |  |  |  |  |  |  |  |  |  |  |  |  |  |  |  |  |
| 1532080da | Write Monitoring Hardware Status FY13 | 95d | 2013-08-30 A | 2013-08-30 A | 9-130M FS+164d, 1532080d FS-95d | 100% |  | 2013-09-18 | 2014-02-10 |  |  |  | SCIENTIST [79.13 h] | 5,931.6 | 5,765.41 | 5765.4118 | 5765.4118 | CHUDAKOV | 1 | 1 | D | S | EUGENE C | ST | 11-006 | 11-026 | 12-021 | 12-053 |  |  |  | 12-054F |  |  |  |  |  |  |  |  |  |  |  |  |  |  |  |  |  |  |  |  |
| 1532080f | Write Monitoring Process Status | 129d | 2013-08-30 A | 2013-08-30 A | 1532035fa, 9-130M FS+130d | 100% |  | 2013-09-03 | 2014-03-14 |  |  |  | SCIENTIST [192 h] | 14,365.5 | 13,989.12 | 13989.12 | 13989.12 | CHUDAKOV | 1 | 1 | D | S | EUGENE C | ST | 11-006 | 11-026 | 12-021 |  |  |  |  | 12-054 |  |  |  |  |  |  |  |  |  |  |  |  |  |  |  |  |  |  |  |  |
| 1532080g | Write Monitoring Trigger | 347d | 2013-08-30 A | 2013-08-30 A | 9-130M, 1532035ga | 100% |  | 2013-09-03 | 2015-01-30 |  |  |  | SCIENTIST [68.7 h] | 5,155.68 | 5,005.48 | 11657.6 | 5005.482 | CHUDAKOV | 1 | 1 | D | S | EUGENE C | ST | 11-006 | 11-026 | 12-021 |  |  |  |  | 12-054 |  |  |  |  |  |  |  |  |  |  |  |  |  |  |  |  |  |  |  |  |
| 1532085 | Write Alarm Sys | 106d | 2013-08-30 A | 2013-08-30 A | 9-130M FS+142d, 1532040 | 100% |  | 2013-09-03 | 2014-02-10 |  |  |  | CONTRB UNIV LBR [440 h]; SCIENTIST [256 h] | 19,134.02 | 18,652.16 | 18652.16 | 18652.16 | CHUDAKOV | 1 | 1 | D | S | EUGENE C | ST | 11-006 | 11-026 | 12-021 |  |  |  |  | 12-054 |  |  |  |  |  |  |  |  |  |  |  |  |  |  |  |  |  |  |  |  |
| 1532090 | Write Archiving DAQ Configuration | 86d | 2013-08-30 A | 2013-08-30 A | 9-130M FS+142d, 1532045 FS+100d | 100% |  | 2013-09-03 | 2014-01-10 |  |  |  | COMP SCIENT [192 h] | 13,318.59 | 13,000.32 | 13000.32 | 13000.32 | CHUDAKOV | 1 | 1 | D | S | EUGENE C | ST | 11-006 | 11-026 | 12-021 |  |  |  |  |  |  |  |  |  |  |  |  |  |  |  |  |  |  |  |  |  |  |  |  |  |
| 1532090a | Write Archiving Run Info | 106d | 2013-08-30 A | 2013-08-30 A | 9-130M FS+142d, 1532045a | 100% |  | 2013-09-03 | 2014-02-10 |  |  |  | COMP SCIENT [256 h] | 17,782.39 | 17,333.76 | 17333.76 | 17333.76 | CHUDAKOV | 1 | 1 | D | S | EUGENE C | ST | 11-006 | 11-026 | 12-021 |  |  |  |  |  |  |  |  |  |  |  |  |  |  |  |  |  |  |  |  |  |  |  |  |  |
| 1532090b | Write Archiving Controls | 126d | 2013-08-30 A | 2013-08-30 A | 1532045b, 9-130M FS+100d | 100% |  | 2013-09-03 | 2014-03-11 |  |  |  | COMP SCIENT [192 h] | 13,349.21 | 13,000.32 | 13000.32 | 13000.32 | CHUDAKOV | 1 | 1 | D | S | EUGENE C | ST | 11-006 | 11-026 | 12-021 |  |  |  |  |  |  |  |  |  |  |  |  |  |  |  |  |  |  |  |  |  |  |  |  |  |
| 1532095 | Write Event Display FY12 | 220d | 2013-08-30 A | 2013-08-30 A | 1532050a, 9-130M FS+110d, 9-120M | 100% |  | 2013-09-03 | 2014-07-23 |  |  |  | CONTRB UNIV LBR [1040 h] |  |  |  | 0 | CHUDAKOV | 1 | 1 | D | Z | EUGENE C |  | 11-006 | 11-026 |  | 12-053 |  |  |  |  |  |  |  |  |  |  |  |  |  |  |  |  |  |  |  |  |  |  |  |  |
| 1532095a | Write Event Display FY13 | 220d | 2013-08-30 A | 2013-08-30 A | 1532095 FS-220d, 9-130M FS+30d | 100% |  | 2013-09-03 | 2014-07-23 |  |  |  | CONTRB UNIV LBR [720 h] |  |  |  | 0 | CHUDAKOV | 1 | 1 | D | Z | EUGENE C |  | 11-006 | 11-026 |  | 12-053 |  |  |  |  |  |  |  |  |  |  |  |  |  |  |  |  |  |  |  |  |  |  |  |  |
| 1532100 | Write Storage Mngmnt | 200d | 2013-08-30 A | 2013-08-30 A | 1532055, 9-130M FS+100d | 100% |  | 2013-09-03 | 2014-06-24 |  |  |  | COMP SCIENT [320 h]; SCIENTIST [32 h] | 24,687.62 | 23,998.72 | 23998.72 | 23998.72 | CHUDAKOV | 1 | 1 | D | S | EUGENE C | ST | 11-006 | 11-026 | 12-021 |  |  |  |  |  |  |  |  |  |  |  |  |  |  |  |  |  |  |  |  |  |  |  |  |  |
| 1532105a | Write Experiment Control Display Management | 208d | 2013-08-30 A | 2013-08-30 A | 9-130M FS+110d, 1532060aa | 100% |  | 2013-09-03 | 2014-07-07 |  |  |  | SCIENTIST [320 h] | 23,986.22 | 23,315.2 | 23315.2 | 23315.2 | CHUDAKOV | 1 | 1 | D | S | EUGENE C | ST | 11-006 | 11-026 | 12-021 |  |  |  |  |  |  |  |  |  |  |  |  |  |  |  |  |  |  |  |  |  |  |  |  |  |
| 1532105b | Write Experiment Control Display Backup/Restore | 72d | 2013-08-30 A | 2013-08-30 A | 1532060ba, 9-130M FS+228d | 100% |  | 2013-09-03 | 2013-12-13 |  |  |  | SCIENTIST [96 h] | 7,155.41 | 6,994.56 | 6994.56 | 6994.56 | CHUDAKOV | 1 | 1 | D | S | EUGENE C | ST | 11-006 | 11-026 | 12-021 |  |  |  |  |  |  |  |  |  |  |  |  |  |  |  |  |  |  |  |  |  |  |  |  |  |
| 1532105c | Write Experiment Control Magnet PS | 170d | 2013-08-30 A | 2013-08-30 A | 9-130M FS+130d, 1532060ca | 100% |  | 2013-09-03 | 2014-05-12 |  |  |  | SCIENTIST [320 h] | 23,970.26 | 23,315.2 | 23315.2 | 23315.2 | CHUDAKOV | 1 | 1 | D | S | EUGENE C | ST | 11-006 | 11-026 | 12-021 |  |  |  |  |  |  |  |  |  |  |  |  |  |  |  |  |  |  |  |  |  |  |  |  |  |
| 1532105h | Write Experiment Control Gas Systems | 200d | 2013-08-30 A | 2013-08-30 A | 1532060ha, 9-130M FS+100d | 100% |  | 2013-09-03 | 2014-06-24 |  |  |  | CONTRB UNIV LBR [160 h]; SCIENTIST [320 h] | 23,983.36 | 23,315.2 | 23315.2 | 23315.2 | CHUDAKOV | 1 | 1 | D | S | EUGENE C | ST | 11-006 | 11-026 | 12-021 |  |  |  |  |  |  |  |  |  |  |  |  |  |  |  |  |  |  |  |  |  |  |  |  |  |
| 1532105j | Write Experiment Control Temerature | 200d | 2013-08-30 A | 2013-08-30 A | 9-130M FS+100d, 1532060ja | 100% |  | 2013-09-03 | 2014-06-24 |  |  |  | SCIENTIST [256 h] | 19,186.69 | 18,652.16 | 18652.16 | 18652.16 | CHUDAKOV | 1 | 1 | D | S | EUGENE C | ST | 11-006 | 11-026 | 12-021 |  |  |  |  |  |  |  |  |  |  |  |  |  |  |  |  |  |  |  |  |  |  |  |  |  |
| 1532105k | Write Experiment Control Target | 201d | 2013-08-30 A | 2013-08-30 A | 1532060ka, 9-130M FS+80d | 100% |  | 2013-09-03 | 2014-06-25 |  |  |  | SCIENTIST [320 h] | 23,983.73 | 23,315.2 | 23315.2 | 23315.2 | CHUDAKOV | 1 | 1 | D | S | EUGENE C | ST | 11-006 | 11-026 | 12-021 |  |  |  |  |  |  |  |  |  |  |  |  |  |  |  |  |  |  |  |  |  |  |  |  |  |
| 1532210 | Re-Baseline Actuals Adjustment | 1d | 2013-08-30 A | 2013-08-30 A |  | 100% |  | 2013-09-03 | 2013-09-03 |  |  |  | PROCUREMENT>$50K 69 NO ESCALATION | -554,366.53 |  |  |  |  |  |  |  |  |  |  |  |  |  |  |  |  |  |  |  |  |  |  |  | 100 |  | ADJ |  |  |  |  |  |  |  |  |  |  |  |  |
| 2532000 | Purchased Labor (Sergey) | 20d | 2013-09-03 A | 2013-09-30 A | 9-130M FS+228d | 100% |  | 2013-10-01 | 2013-10-28 |  |  | 8/5 M-F w/JLAB Holidays ReBaseline | PROCUREMENT<$50K 60 | 1,572.8 |  |  | 0 | CHUDAKOV | 1 | 1 | D | E | EUGENE C |  | 11-006 | 11-026 |  |  | 07-024 |  |  |  |  |  | 0 | 1572.8 | 157280 | 100 |  |  | 100 | 100 | 2532013E | 1572.8 | 13-007F | PE | 13-015 | PR | OB |  |  |  |
| 2532013E | FY13 Travel (ONLINE COMP) | 20d | 2013-09-03 A | 2013-09-30 A | 9-130M FS+228d | 100% |  | 2013-10-01 | 2013-10-28 |  |  | 8/5 M-F w/JLAB Holidays ReBaseline | TRAVEL | 129.3 |  |  | 0 | CHUDAKOV | 1 | 1 | D | E | EUGENE C |  | 11-006 | 11-026 |  |  | 07-024 |  |  |  |  |  |  |  |  |  |  |  | 100 | 100 | 2532013E | 129.3 | 13-007F | PE | 13-015 | PR |  |  |  |  |
| 2532020 | Coordination of online computing setup | 20d | 2013-09-03 A | 2013-09-30 A | 9-130M FS+228d | 100% |  | 2013-10-01 | 2013-10-28 |  |  | 8/5 M-F w/JLAB Holidays ReBaseline | SCIENTIST [12 h] | 902.16 | 874.32 |  | 0 | CHUDAKOV | 1 | 1 | D | E | EUGENE C |  | 11-006 | 11-026 | 12-021 |  |  |  |  | 12-054 |  |  |  |  |  |  |  |  | 100 | 100 | 2532020 | 874.32 | 13-007 |  | 13-015 | PR |  | EJ |  |  |
| 2532035 | Create scripts to launch and kill: CODA system, monitoring system FY13 | 20d | 2013-09-03 A | 2014-01-17 | 9-130M FS+228d |  | 46d | 2013-10-01 | 2013-10-28 | 65d | 34d | 8/5 M-F w/JLAB Holidays ReBaseline | SCIENTIST [35.96 h] | 2,703.47 | 1,287.42 |  | 0 | CHUDAKOV | 1 | 1 | D | S | EUGENE C | ST | 11-006 | 11-026 | 12-021 |  |  |  |  | 12-054 |  |  |  |  |  |  |  |  |  |  | 2532035 |  | 13-007 |  | 13-015 | PR |  | EJ |  |  |
| 2532035a | Create scripts to launch and kill: CODA system, monitoring system FY14 | 69d | 2013-09-03 A | 2014-01-17 | 2532035 FS-80d |  | 46d | 2013-10-29 | 2014-02-17 | 65d |  | 8/5 M-F w/JLAB Holidays ReBaseline | SCIENTIST [124.04 h] | 9,325.33 | 4,440.83 |  | 0 | CHUDAKOV | 1 | 1 | D | S | EUGENE C | ST | 11-006 | 11-026 | 12-021 |  |  |  |  | 12-054 |  |  |  |  |  |  |  |  |  |  | 2532035 |  | 13-007 |  | 13-015 | PR |  | EJ | 14-001 |  |
| 2532040 | Run bookkeeping scripts (database;data files and special events) FY13 | 20d | 2013-09-03 A | 2014-03-13 | 9-130M FS+228d |  | 84d | 2013-10-01 | 2013-10-28 | 27d |  | 8/5 M-F w/JLAB Holidays ReBaseline | SCIENTIST [37.8 h] | 2,841.8 | 948.38 |  | 0 | CHUDAKOV | 1 | 1 | D | S | EUGENE C | ST | 11-006 | 11-026 | 12-021F |  |  |  |  | 12-054F |  |  |  |  |  |  |  |  |  |  | 2532040 |  | 13-007F |  | 13-015 | PR |  | EJ |  |  |
| 2532040a | Run bookkeeping scripts (database;data files and special events) FY14 | 107d | 2013-09-03 A | 2014-03-13 | 2532040 FS-120d |  | 84d | 2013-10-29 | 2014-04-10 | 27d |  | 8/5 M-F w/JLAB Holidays ReBaseline | SCIENTIST [202.2 h] | 15,201.4 | 5,073.05 |  | 0 | CHUDAKOV | 1 | 1 | D | S | EUGENE C | ST | 11-006 | 11-026 | 12-021F |  |  |  |  | 12-054F |  |  |  |  |  |  |  |  |  |  | 2532040 |  | 13-007F |  | 13-015 | PR |  | EJ | 14-001 |  |
| 2532050 | Readout Lists FY13 | 20d | 2013-09-03 A | 2014-04-21 | 9-130M FS+228d |  | 111d | 2013-10-01 | 2013-10-28 | 0d |  | 8/5 M-F w/JLAB Holidays ReBaseline | SCIENTIST [31.17 h] | 2,343.36 | 644.92 |  | 0 | CHUDAKOV | 1 | 1 | D | S | EUGENE C | ST | 11-006 | 11-026 | 12-021F |  |  |  |  | 12-054F |  |  |  |  |  |  |  |  |  |  | 2532050 |  | 13-007F |  | 13-015 | PR |  | EJ |  |  |
| 2532050a | Readout Lists FY14 | 134d | 2013-09-03 A | 2014-04-21 | 2532050 FS-140d |  | 111d | 2013-10-29 | 2014-05-19 | 0d |  | 8/5 M-F w/JLAB Holidays ReBaseline | SCIENTIST [208.83 h] | 15,699.84 | 4,320.8 |  | 0 | CHUDAKOV | 1 | 1 | D | S | EUGENE C | ST | 11-006 | 11-026 | 12-021F |  |  |  |  | 12-054F |  |  |  |  |  |  |  |  |  |  | 2532050 |  | 13-007F |  | 13-015 | PR |  | EJ | 14-001 |  |
| 2532070 | Implement Translation Tables FY13 | 20d | 2013-09-03 A | 2014-01-17 | 2532030 FS-118d |  | 46d | 2013-10-01 | 2013-10-28 | 65d | 54d | 8/5 M-F w/JLAB Holidays ReBaseline | SCIENTIST [9.17 h] | 689.4 | 328.3 |  | 0 | CHUDAKOV | 1 | 1 | D | S | EUGENE C | ST | 11-006 | 11-026 | 12-021 |  |  |  |  |  |  |  |  |  |  |  |  |  |  |  | 2532070 |  | 13-007 |  | 13-015 | PR |  | EJ |  |  |
| 2532070a | Implement Translation Tables FY14 | 69d | 2013-09-03 A | 2014-01-17 | 2532070 FS-100d |  | 46d | 2013-10-29 | 2014-02-17 | 65d |  | 8/5 M-F w/JLAB Holidays ReBaseline | SCIENTIST [31.63 h] | 2,377.94 | 1,132.4 |  | 0 | CHUDAKOV | 1 | 1 | D | S | EUGENE C | ST | 11-006 | 11-026 | 12-021 |  |  |  |  |  |  |  |  |  |  |  |  |  |  |  | 2532070 |  | 13-007 |  | 13-015 | PR |  | EJ | 14-001 |  |
| 2532075 | Farm Process Manager | 204d | 2013-09-03 A | 2014-09-29 | 2532030 FS-100d | 30% | 223d | 2013-12-02 | 2014-09-29 | 1d |  | 8/5 M-F w/JLAB Holidays ReBaseline | SCIENTIST [280 h] | 21,050.4 | 3,354.04 |  | 0 | CHUDAKOV | 1 | 1 | D | S | EUGENE C | ST | 11-006 | 11-026 | 12-021 |  |  |  |  | 12-054F |  | IPL |  |  |  |  |  |  |  |  | 2532075 | 6315.12 | 13-007 |  | 13-015 | PR |  | EJ | 14-001 |  |
| 2532080 | ROOTSpy enabled Monitoring Processes FY13 | 20d | 2013-09-03 A | 2014-02-04 | 2532030 FS-118d | 12% | 57d | 2013-10-01 | 2013-10-28 | 39d | 0d | 8/5 M-F w/JLAB Holidays ReBaseline | SCIENTIST [51.2 h] | 3,849.22 | 1,631.41 |  | 466.304 | CHUDAKOV | 1 | 1 | D | S | EUGENE C | ST | 11-006 | 11-026 | 12-021 |  |  |  |  | 12-054F |  | IPL |  |  |  |  |  |  |  |  | 2532080 |  | 13-007 |  | 13-015 | PR |  | EJ |  |  |
| 2532080a | ROOTSpy enabled Monitoring Processes FY14 | 80d | 2013-09-03 A | 2014-02-04 | 2532080 FS-80d | 12% | 57d | 2013-10-01 | 2014-02-04 | 39d | 0d | 8/5 M-F w/JLAB Holidays ReBaseline | SCIENTIST [204.8 h] | 15,396.86 | 6,525.62 |  | 1924.608 | CHUDAKOV | 1 | 1 | D | S | EUGENE C | ST | 11-006 | 11-026 | 12-021 |  |  |  |  | 12-054F |  | IPL |  |  |  |  |  |  |  |  | 2532080 |  | 13-007 |  | 13-015 | PR |  | EJ | 14-001 |  |
| 2532170a | HV Controls (FDC; CDC; TOF; FCAL; HODO) Phase 2 FY13 | 105d | 2013-09-03 A | 2014-05-30 | 9-130M FS+228d | 25% | 139d | 2013-10-01 | 2014-03-11 | 85d | 1d | 8/5 M-F w/JLAB Holidays ReBaseline | MECH TECH [30.48 h]; SCIENTIST [30.48 h] | 3,733.19 | 869.36 |  | 0 | CHUDAKOV | 1 | 1 | D | S | EUGENE C | ST | 11-006 | 11-026 | 12-021 |  |  |  |  |  |  |  |  |  |  |  |  |  |  |  | 2532170a | 904.498 |  |  | 13-015 | PR |  | EJ |  | 12-040 |
| 2532170aa | HV Controls (FDC; CDC; TOF; FCAL; HODO) Phase 2 FY14 | 85d | 2013-09-03 A | 2014-05-30 | 2532170a FS-140d | 25% | 139d | 2013-10-01 | 2014-02-11 | 85d |  | 8/5 M-F w/JLAB Holidays ReBaseline | MECH TECH [129.53 h]; SCIENTIST [129.53 h] | 15,866.81 | 3,694.95 |  | 0 | CHUDAKOV | 1 | 1 | D | S | EUGENE C | ST | 11-006 | 11-026 | 12-021 |  |  |  |  |  |  |  |  |  |  |  |  |  |  |  | 2532170a | 3966.703125 |  |  | 13-015 | PR |  | EJ | 14-001 | 12-040 |
| 2532175 | LV Controls (BCAl; ST; FDC) FY13 | 140d | 2013-09-03 A | 2013-09-23 A | 9-130M FS+228d | 100% |  | 2013-10-01 | 2014-04-29 |  |  | 8/5 M-F w/JLAB Holidays ReBaseline | MECH TECH [7.14 h]; SCIENTIST [5.72 h] | 767.78 | 744.08 |  | 0 | CHUDAKOV | 1 | 1 | D | S | EUGENE C | ST | 11-006 | 11-026 | 12-021 |  |  |  |  |  |  |  |  |  |  |  |  |  |  |  | 2532175 | 744.079612 |  |  | 13-015 | PR |  | EJ |  | 12-040 |
| 2532175b | LV Controls (BCAl; ST; FDC) FY14 | 120d | 2013-09-03 A | 2013-09-23 A | 2532175 | 100% |  | 2013-10-01 | 2014-04-01 |  |  | 8/5 M-F w/JLAB Holidays ReBaseline | MECH TECH [42.86 h]; SCIENTIST [34.28 h] | 4,605.42 | 4,463.32 |  | 0 | CHUDAKOV | 1 | 1 | D | S | EUGENE C | ST | 11-006 | 11-026 | 12-021 |  |  |  |  |  |  |  |  |  |  |  |  |  |  |  | 2532175 | 4605.42941 |  |  | 13-015 | PR |  | EJ | 14-001 | 12-040 |
| 2532205 | Motors (radiator, converter, collimator, tagger) FY13 | 20d | 2013-09-03 A | 2014-03-04 | 9-130M FS+228d |  | 77d | 2013-10-01 | 2013-10-28 | 20d | 9d | 8/5 M-F w/JLAB Holidays ReBaseline | MECH TECH [53.33 h]; SCIENTIST [26.67 h] | 4,528.53 | 1,599.44 |  | 0 | CHUDAKOV | 1 | 1 | D | S | EUGENE C | ST | 11-006 | 11-026 | 12-021 |  |  |  |  |  |  |  |  |  |  |  |  |  |  |  | 2532205 |  |  |  | 13-015 | PR |  | EJ |  | 12-040 |
| 2532205a | Motors (radiator, converter, collimator, tagger) FY14 | 100d | 2013-09-03 A | 2014-03-04 | 2532205 FS-100d |  | 77d | 2013-10-29 | 2014-04-01 | 20d | 9d | 8/5 M-F w/JLAB Holidays ReBaseline | MECH TECH [266.67 h]; SCIENTIST [133.33 h] | 22,642.67 | 7,997.18 |  | 0 | CHUDAKOV | 1 | 1 | D | S | EUGENE C | ST | 11-006 | 11-026 | 12-021 |  |  |  |  |  |  |  |  |  |  |  |  |  |  |  | 2532205 |  |  |  | 13-015 | PR |  | EJ | 14-001 | 12-040 |
| 2532215 | CSS Control GUIs FY13 | 20d | 2013-09-03 A | 2014-03-17 | 9-130M FS+228d |  | 86d | 2013-10-01 | 2013-10-28 | 11d | 0d | 8/5 M-F w/JLAB Holidays ReBaseline | SCIENTIST [24.81 h]; MECH TECH [37.21 h] | 3,625.94 | 1,191.3 |  | 0 | CHUDAKOV | 1 | 1 | D | S | EUGENE C | ST | 11-006 | 11-026 | 12-021 |  |  |  |  |  |  |  |  |  |  |  |  |  |  |  | 2532215 |  |  |  | 13-015 | PR |  | EJ |  | 12-040 |
| 2532215a | CSS Control GUIs FY14 | 109d | 2013-09-03 A | 2014-03-17 | 2532215 FS-110d |  | 86d | 2013-10-29 | 2014-04-14 | 11d | 0d | 8/5 M-F w/JLAB Holidays ReBaseline | SCIENTIST [135.19 h]; MECH TECH [202.79 h] | 19,759.66 | 6,492.02 |  | 0 | CHUDAKOV | 1 | 1 | D | S | EUGENE C | ST | 11-006 | 11-026 | 12-021 |  |  |  |  |  |  |  |  |  |  |  |  |  |  |  | 2532215 |  |  |  | 13-015 | PR |  | EJ | 14-001 | 12-040 |
| 2532230 | Alarms (configuration,display, history) FY13 | 45d | 2013-09-03 A | 2013-11-08 | 9-130M FS+228d | 20% | 6d | 2013-10-01 | 2013-12-04 | 79d | 0d | 8/5 M-F w/JLAB Holidays ReBaseline | SCIENTIST [71.11 h]; VISTNG USERS [213.33 h] | 9,738.51 | 8,422.97 |  | 0 | CHUDAKOV | 1 | 1 | D | S | EUGENE C | ST | 11-006 | 11-026 | 12-021 |  |  |  |  |  |  |  |  |  |  |  |  |  |  |  | 2532230 | 1887.40162 |  |  | 13-015 | PR |  | EJ |  | 12-040 |
| 2532230a | Alarms (configuration,display, history) FY14 | 25d | 2013-09-03 A | 2013-11-08 | 2532230 FS-25d | 20% | 6d | 2013-10-01 | 2013-11-04 | 79d | 0d | 8/5 M-F w/JLAB Holidays ReBaseline | SCIENTIST [88.89 h]; VISTNG USERS [266.67 h] | 12,173.49 | 10,529.02 |  | 0 | CHUDAKOV | 1 | 1 | D | S | EUGENE C | ST | 11-006 | 11-026 | 12-021 |  |  |  |  |  |  |  |  |  |  |  |  |  |  |  | 2532230 | 2434.6971 |  |  | 13-015 | PR |  | EJ | 14-001 | 12-040 |
| 2532175a | LV Controls (BCAl; ST; FDC) Phase 2 | 127d | 2013-09-16 A | 2014-07-15 | 2532175, 2532175b | 75% | 170d | 2014-04-30 | 2014-10-28 | 54d |  | 8/5 M-F w/JLAB Holidays ReBaseline | MECH TECH [200 h]; SCIENTIST [160 h] | 21,492.8 | 3,546.37 |  | 10746.4 | CHUDAKOV | 1 | 1 | D | S | EUGENE C | ST | 11-006 | 11-026 | 12-021 |  |  |  |  |  |  |  |  |  |  |  |  |  |  |  | 2532175a | 5373.2 |  |  | 13-015 | PR |  | EJ | 14-001 | 12-040 |
| 2532005 | Install OS system along with network settings FY13 | 20d | 2013-10-01 A | 2013-12-03 | 9-130M FS+228d, 9-140M FS+10d | 50% | 21d | 2013-11-01 | 2013-12-02 | 58d | 0d | 8/5 M-F w/JLAB Holidays ReBaseline | SR STAFF [11.43 h] | 1,375.26 | 718.88 |  | 666.369 | CHUDAKOV | 1 | 1 | D | H | EUGENE C |  | 11-006 | 11-026 | 12-021 |  | 07-024 | 07-027 | 531 | 12-054 |  |  |  |  |  |  |  |  |  |  | 2532005 |  | 13-007 |  | 13-015 | PR |  | EJ |  |  |
| 2532005a | Install OS system along with network settings FY14 | 20.75d | 2013-10-01 A | 2013-12-03 | 2532005 FS-25d | 50% | 20.75d | 2013-12-03 | 2014-01-10 | 58.25d | 0.25d | 8/5 M-F w/JLAB Holidays ReBaseline | SR STAFF [12.57 h] | 1,512.42 | 795.1 |  | 756.2112 | CHUDAKOV | 1 | 1 | D | H | EUGENE C |  | 11-006 | 11-026 | 12-021 |  | 07-024 | 07-027 | 531 | 12-054 |  |  |  |  |  |  |  |  |  |  | 2532005 |  | 13-007 |  | 13-015 | PR |  | EJ | 14-001 |  |

Notes:
- 1532105: Steps: Design a directory structure and a makefile scheme for EPCS (done); Setup PLC framework (done); Create CSS product for Hall D (done); Setup gateway for EPICS (done); Create scripts for automatic booting oF IOCs (done)
- 1532105s: Steps: Design a directory structure and a makefile scheme for EPCS (done); Setup PLC framework (done); Create CSS product for Hall D (done); Setup gateway for EPICS (done); Create scripts for automatic booting oF IOCs (done)
- 1532080: Steps: Implement electronics Inventory System (done); Install/Configure E-Log (done); Install/Configure Bug Tracker/Problem Reporting (Mantis) (done); Install/Configure Remote Management/Monitoring System on CH computers (done); Install/Configure Remote Management/Monitoring System on DAQ front-end computers (done); Setup Hall-D Operator's Manual (wiki) (done); Write Monitoring daemon (done); Write Monitoring GUI (done); Add sections to Operator's manual (done); Test system (done)
- 1532082: Steps: Implement electronics Inventory System (done); Install/Configure E-Log (done); Install/Configure Bug Tracker/Problem Reporting (Mantis) (done); Install/Configure Remote Management/Monitoring System on CH computers (done); Install/Configure Remote Management/Monitoring System on DAQ front-end computers (done); Setup Hall-D Operator's Manual (wiki) (done); Write Monitoring daemon (done); Write Monitoring GUI (done); Add sections to Operator's manual (done); Test system (done)
- 1532105d: Steps: Finish CAEN SY1527 driver (done); Write EPICS driver for IU bases (done); Interface with configuration DB (done); EPICS IOC DB configuration (done); Generation of HV GUIs for FCAL (done); Generation of HV GUIs for FDC (done); Generation of HV GUIs for FDC (done); Generation of HV GUIs for TOF (done); Generation of HV GUIs for tagger (done); Configuration of HV alarm handler (done); Documentation (done)
- 1532105da: Steps: Finish CAEN SY1527 driver (done); Write EPICS driver for IU bases (done); Interface with configuration DB (done); EPICS IOC DB configuration (done); Generation of HV GUIs for FCAL (done); Generation of HV GUIs for FDC (done); Generation of HV GUIs for FDC (done); Generation of HV GUIs for TOF (done); Generation of HV GUIs for tagger (done); Configuration of HV alarm handler (done); Documentation (done)
- 1532105f: Steps: Write specs for Uconn EPICS driver (done); Intergrate Uconn controls software into EPICS (done); Interface wih configuration DB (done); EPICS IOC DB configuration (done); Generation of LV GUIs for BCAL (done); Generation of LV for microscope (done); Generation of LV GUIs for DCs (done); Generation of LV GUIs for ST (done); Conficuration of LV alarm handler (done); Documentation (done)
- 1532105fa: Steps: Write specs for Uconn EPICS driver (done); Intergrate Uconn controls software into EPICS (done); Interface wih configuration DB (done); EPICS IOC DB configuration (done); Generation of LV GUIs for BCAL (done); Generation of LV for microscope (done); Generation of LV GUIs for DCs (done); Generation of LV GUIs for ST (done); Conficuration of LV alarm handler (done); Documentation (done)
- 1532075c: Explanation: IPL from 6 GeV 571130
- 1532080b: Steps: Install DB Server in CH (done); Define DB tables and implement automatic backups (done); Install/Configure Farm Management System on all monitoring nodes (done); Write command line tools for starting/stopping histogram monitoring processes (done); Write accumulator/archiver program (done); Write GUI for managing farm processes (done); Write Monitoring Farm DAQ Component (done); Add section to Operator's Manual (done); Test system (done)
- 1532080ba: Steps: Install DB Server in CH (done); Define DB tables and implement automatic backups (done); Install/Configure Farm Management System on all monitoring nodes (done); Write command line tools for starting/stopping histogram monitoring processes (done); Write accumulator/archiver program (done); Write GUI for managing farm processes (done); Write Monitoring Farm DAQ Component (done); Add section to Operator's Manual (done); Test system (done)
- 1532075: Explanation: IPL from 6 GeV 571130 / Steps: Write DAQ Software Event Unblocking (done)
- 1532080c: Steps: Write Monitoring Remote (done)
- 1532105n: Steps: Write C-message/ChannelAccess interface (done); Create a prototype application with C-message/CA interface and test it (done); Define and implement states for slow controls in EPICS (done); Alarms system from AFECS components (done)
- 1532105na: Steps: Write C-message/ChannelAccess interface (done); Create a prototype application with C-message/CA interface and test it (done); Define and implement states for slow controls in EPICS (done); Alarms system from AFECS components (done)
- 1532065c: Steps: Prototype Level-1 (L1) Control (done); Prototype Level-1 Client Process on ROC (done); Prototype Run Configuration Database (done); Prototype Interface between the L1 Control and Run Control and DB (done); Expert GUI Development (done); Check Prototype Performance (done); Final Implementation (done)
- 1532070: Steps: Write Front-End Software (done)
- 1532075a: Explanation: IPL from 6 GeV 571130 / Steps: Create Scripts directory structure in repository (done); Create special accounts with appropriate permissions on HDCC (Hall-D Computing Cluster) (done); Document scripts directory structure and access restrictions in Operator's Manual (done); Write online utility scripts (command-line) (done); Write GUI scripts (done)
- 1532075b: Explanation: IPL from 6 GeV 571130 / Steps: Create Run Control GUI using CSS/BOY (done); Interface between AFECS and EPICS state machines (done); Design and implement trigger control GUI (done)
- 1532075ba: Explanation: IPL from 6 GeV 571130 / Steps: Create Run Control GUI using CSS/BOY (done); Interface between AFECS and EPICS state machines (done); Design and implement trigger control GUI (done)
- 1532077: Explanation: IPL from 6 GeV 571130 / Steps: Write DAQ Software Scripts FY13 (done)
- 1532080a: Steps: Write Monitoring Scalers (done)
- 1532080d: Steps: Monitoring Crates (done); Monitoring Network Swithces (done); Monitoring online farm nodes (done); Monitoring PLC and IOCs (done); Monitoring UPS status and shutdown procedure (done); Monitoring RAID status (done); Documentation (done)
- 1532080da: Steps: Monitoring Crates (done); Monitoring Network Swithces (done); Monitoring online farm nodes (done); Monitoring PLC and IOCs (done); Monitoring UPS status and shutdown procedure (done); Monitoring RAID status (done); Documentation (done)
- 1532080f: Steps: Write Monitoring Process Status (done)
- 1532080g: Steps: Write Monitoring Trigger (done)
- 1532085: Steps: Write Alarm Sys (done)
- 1532090: Steps: Write Archiving DAQ Configuration (done)
- 1532090a: Steps: Write Archiving Run Info (done)
- 1532090b: Steps: Write Archiving Controls (done)
- 1532100: Steps: Write Storage Mngmnt (done)
- 1532105a: Steps: Write Experiment Control Display Management (done)
- 1532105b: Steps: Write Experiment Control Display Backup/Restore (done)
- 1532105c: Steps: Write Experiment Control Magnet PS (done)
- 1532105h: Steps: Write Experiment Control Gas Systems (done)
- 1532105j: Steps: Write Experiment Control Temerature (done)
- 1532105k: Steps: Write Experiment Control Target (done)
- 2532035: Steps: Monitoring system scripts; L3 scripts; CODA scipts; ET scripts; Global integration
- 2532035a: Steps: Monitoring system scripts; L3 scripts; CODA scipts; ET scripts; Global integration
- 2532040: Steps: define API and tables; implement database; write run transition scripts; write scripts to insert special events into datastream
- 2532040a: Steps: define API and tables; implement database; write run transition scripts; write scripts to insert special events into datastream
- 2532050: Steps: general planning (different crates; tag IDs); First pass (separate ROL by module types); Second pass (combine ROLs into single generic ROL with crate scanning; Trigger integration; Trigger ROLs (TS and GTP); Special ROLs (calibration; detector segmentation); Board Config (download)
- 2532050a: Steps: general planning (different crates; tag IDs); First pass (separate ROL by module types); Second pass (combine ROLs into single generic ROL with crate scanning; Trigger integration; Trigger ROLs (TS and GTP); Special ROLs (calibration; detector segmentation); Board Config (download)
- 2532070: Steps: Parse EVIO file and generate DANA detector hit objects using T-tables
- 2532070a: Steps: Parse EVIO file and generate DANA detector hit objects using T-tables
- 2532075: Explanation: IPL from 6 GeV 571130 / Steps: Specification, Implementation of communication protocol plugin (done); Final specification of States and Transitions (done); Implementation of Manager in AFECS; Testing of farm manager in Counting House
- 2532080: Explanation: IPL from 6 GeV 571130 / Steps: Write dedicated hd_online program (done); Implement final hists mechanism by interfacing w/ DAQ via farm manager; Test system on a farm using operators displays in control room
- 2532080a: Explanation: IPL from 6 GeV 571130 / Steps: Write dedicated hd_online program (done); Implement final hists mechanism by interfacing w/ DAQ via farm manager; Test system on a farm using operators displays in control room
- 2532170a: Steps: EPICS driver for FCAL bases and chassis; IOCs for FCAL TOF HODO PS HV (done); Control GUIs for FCAL HV; Constrol GUIs for TOF; PS and HODO HV
- 2532170aa: Steps: EPICS driver for FCAL bases and chassis; IOCs for FCAL TOF HODO PS HV (done); Control GUIs for FCAL HV; Constrol GUIs for TOF; PS and HODO HV
- 2532175: Steps: LV Controls (BCAl; ST; FDC) FY13 (done)
- 2532175b: Steps: LV Controls (BCAl; ST; FDC) FY14 (done)
- 2532205: Steps: Collimator controls; Converter controls; Radiator controls; Microscope support controls; EPICS for goniometer; Harp scans
- 2532205a: Steps: Collimator controls; Converter controls; Radiator controls; Microscope support controls; EPICS for goniometer; Harp scans
- 2532215: Steps: Solenoid GUIs; PS; Tagger; Sweeping magnet GUIs; Main EPICS GUIs; Gas system GUIs; Temperature/Humidity GUIs; Beamline GUIs; Target GUIs
- 2532215a: Steps: Solenoid GUIs; PS; Tagger; Sweeping magnet GUIs; Main EPICS GUIs; Gas system GUIs; Temperature/Humidity GUIs; Beamline GUIs; Target GUIs
- 2532230: Steps: Configure MySQL DB; JMS; and CSS (done); Configure authorization and authentication for CSS alarms; Populate alarm DB; Installation in the control room; Documentation
- 2532230a: Steps: Configure MySQL DB; JMS; and CSS (done); Configure authorization and authentication for CSS alarms; Populate alarm DB; Installation in the control room; Documentation
- 2532175a: Steps: DB configuration (done); BCAL LV/Bias GUIs (done); ST LV/Bias GUIs; FDC LV GUIs (done)

| ID | Activity | Duration | Start | Finish | Predecessors | Complete | Remaining | Planned start | Planned finish | Total float | Free float | Calendar | Resources | Cost | Actual cost | LOE % Pre Calc | LOE % | LOE Divider | LOE Multiplier | Original Activity ID Rebaseline | MONTHLY EV COST | RESP - Responsibility | STRT%COMP for CM EVM | FNSH%COMP for CM EVM | HALL D Related Milestones | CR 07-024 | EVMS Reporting Codes | CAM RESPONSIBLE | CR 11-006 | CR 11-026 | CR 13-007 | BOE Expenses | CR 13-015 | Post Rebaseline | CR 14-001 | Activities with Steps | CR 12-021 | CR 12-054 | BOE Labor | CR 12-040 |
| --- | --- | --- | --- | --- | --- | --- | --- | --- | --- | --- | --- | --- | --- | --- | --- | --- | --- | --- | --- | --- | --- | --- | --- | --- | --- | --- | --- | --- | --- | --- | --- | --- | --- | --- | --- | --- | --- | --- | --- | --- |
| 2532014E | FY14 Travel (ONLINE COMP) | 246d | 2013-10-01 A | 2014-09-29 | 2532013E | 9% | 223d | 2013-11-01 | 2014-10-30 | 501d |  | 8/5 M-F w/JLAB Holidays ReBaseline | TRAVEL | 1,648.18 |  | 90.6504065 | 9.34959349 | 100 | 100 | 2532014E | 154.10483 | CHUDAKOV | 1 | 1 | D | 07-024 | E | EUGENE C | 11-006 | 11-026 | 13-007F | PE | 13-015 | PR | 14-001 |  |  |  |  |  |
| 2532085 | Archiving and Retrieval of Histogram Files | 138d | 2013-10-21 A | 2014-09-16 | 9-140M, 2532030 FS-80d | 30% | 214d | 2014-03-03 | 2014-09-15 | 10d |  | 8/5 M-F w/JLAB Holidays ReBaseline | SCIENTIST [200 h] | 15,036 | 606.83 |  |  |  |  | 2532085 | 4510.8 | CHUDAKOV | 1 | 1 | D |  | S | EUGENE C | 11-006 | 11-026 | 13-007 |  | 13-015 | PR | 14-001 | ST | 12-021 | 12-054 | EJ |  |
| 2532055 | Write COOL Config Files | 79d | 2013-11-01 | 2014-03-06 | 2532030 FS-75d |  |  |  |  | 32d |  | 8/5 M-F w/JLAB Holidays ReBaseline | SCIENTIST [160 h] | 12,028.8 |  |  |  |  |  | 2532055 | 0 | CHUDAKOV | 1 | 1 | D |  | S | EUGENE C | 11-006 | 11-026 | 13-007F |  | 13-015 | PR | 14-001 | ST | 12-021F | 12-054F | EJ |  |
| 2532100 | Transport from RAID to Tape Silo | 86d | 2013-11-01 | 2014-03-17 | 9-140M FS+23d |  |  |  |  | 2d | 0d | 8/5 M-F w/JLAB Holidays ReBaseline | SR STAFF [160 h] | 19,251.2 |  |  |  |  |  | 2532100 | 0 | CHUDAKOV | 1 | 1 | D |  | S | EUGENE C | 11-006 | 11-026 | 13-007 |  | 13-015 | PR | 14-001 | ST | 12-021 |  | EJ |  |
| 2532250 | EPICS Archving and Restoration FY13 | 20d | 2013-11-01 | 2013-12-02 | 9-130M FS+228d |  |  |  |  | 0d |  | 8/5 M-F w/JLAB Holidays ReBaseline | SCIENTIST [34.53 h] | 2,595.97 |  |  |  |  |  | 2532250 | 0 | CHUDAKOV | 1 | 1 | D |  | S | EUGENE C | 11-006 | 11-026 |  |  | 13-015 | PR |  | ST | 12-021 |  | EJ | 12-040 |
| 2532245 | DAQ monitoring Software | 125d | 2013-11-27 | 2014-06-06 | 9-140M FS+41.5d |  |  |  |  | 80.5d |  | 8/5 M-F w/JLAB Holidays ReBaseline | SCIENTIST [160 h] | 12,028.8 |  |  |  |  |  | 2532245 | 0 | CHUDAKOV | 1 | 1 | D |  | S | EUGENE C | 11-006 | 11-026 |  |  | 13-015 | PR | 14-001 | ST | 12-021 |  | EJ | 12-040 |
| 2532030 | Install CODA and supporting software | 56d | 2013-12-02 | 2014-02-28 | 9-140M FS+42d |  |  |  |  | 15d | 0d | 8/5 M-F w/JLAB Holidays ReBaseline | SCIENTIST [80 h] | 6,014.4 |  |  |  |  |  | 2532030 | 0 | CHUDAKOV | 1 | 1 | D |  | S | EUGENE C | 11-006 | 11-026 | 13-007 |  | 13-015 | PR | 14-001 | ST | 12-021 | 12-054 | PE |  |
| 2532115 | Archiving DAQ Configuration | 125d | 2013-12-02 | 2014-06-06 | 2532030 FS-56d |  |  |  |  | 80d |  | 8/5 M-F w/JLAB Holidays ReBaseline | SCIENTIST [160 h] | 12,028.8 |  |  |  |  |  | 2532115 | 0 | CHUDAKOV | 1 | 1 | D |  | S | EUGENE C | 11-006 | 11-026 | 13-007 |  | 13-015 | PR | 14-001 | ST | 12-021 | 12-054 | EJ |  |
| 2532145 | Temperature/Humidity monitoring | 48d | 2013-12-02 | 2014-02-18 | 9-140M FS+42d |  |  |  |  | 30d |  | 8/5 M-F w/JLAB Holidays ReBaseline | MECH ENG [160 h] | 11,947.2 |  |  |  |  |  | 2532145 | 0 | CHUDAKOV | 1 | 1 | D |  | S | EUGENE C | 11-006 | 11-026 | 13-007 |  | 13-015 | PR | 14-001 | ST | 12-021 |  | EJ | 12-040 |
| 2532190 | Sweeping and pair spectrometer magnet control SWT (accel Grp) | 54d | 2013-12-02 | 2014-02-26 | 2553035 FS+30d, 9-140M FS+42d |  |  |  |  | 24d | 13d | 8/5 M-F w/JLAB Holidays ReBaseline | ELEC ENG; COMP SCIENT [80 h] | 5,589.6 |  |  |  |  |  | 2532190 | 0 | CHUDAKOV | 1 | 1 | D |  | S | EUGENE C | 11-006 | 11-026 | 13-007 |  | 13-015 | PR | 14-001 | ST | 12-021 |  | EJ | 12-040 |
| 2532250a | EPICS Archving and Restoration FY14 | 96d | 2013-12-03 | 2014-04-28 | 2532250 |  |  |  |  | 0d |  | 8/5 M-F w/JLAB Holidays ReBaseline | SCIENTIST [205.47 h] | 15,447.23 |  |  |  |  |  | 2532250 | 0 | CHUDAKOV | 1 | 1 | D |  | S | EUGENE C | 11-006 | 11-026 |  |  | 13-015 | PR | 14-001 | ST | 12-021 |  | EJ | 12-040 |
| 2532015 | Database web-server wiki installations | 32d | 2013-12-04 | 2014-01-29 | 2532005a, 2532005, 2532030 FS-56d |  |  |  |  | 58d |  | 8/5 M-F w/JLAB Holidays ReBaseline | SR STAFF [80 h] | 9,625.6 |  |  |  |  |  | 2532015 | 0 | CHUDAKOV | 1 | 1 | D |  | H | EUGENE C | 11-006 | 11-026 | 13-007 |  | 13-015 | PR | 14-001 |  | 12-021 | 12-054 | PE |  |
| 2532185 | Tagger magnet and NMR control SWT (accel Grp) | 55d | 2013-12-10 | 2014-03-07 | 9-140M FS+42d, 2562050a FS+17d, 2562050 FS+17d |  |  |  |  | 17d | 6d | 8/5 M-F w/JLAB Holidays ReBaseline | ELEC ENG; COMP SCIENT [160 h] | 11,179.2 |  |  |  |  |  | 2532185 | 0 | CHUDAKOV | 1 | 1 | D |  | S | EUGENE C | 11-006 | 11-026 | 13-007 |  | 13-015 | PR | 14-001 | ST | 12-021 |  | EJ | 12-040 |
| 2532135 | BCAL Gas System Controls | 34d | 2013-12-16 | 2014-02-12 | 2562830 FS+37d, 2562830a FS+37d |  |  |  |  | 34d |  | 8/5 M-F w/JLAB Holidays ReBaseline | MECH ENG [80 h] | 5,973.6 |  |  |  |  |  | 2532135 | 0 | CHUDAKOV | 1 | 1 | D |  | H | EUGENE C | 11-006 | 11-026 |  |  | 13-015 | PR | 14-001 |  | 12-021 |  | EJ | 12-040 |
| 2532140 | Controls for Chillers (FDC;BCAL;Target) | 68d | 2013-12-16 | 2014-04-01 | 9-140M FS+52d |  |  |  |  | 0d |  | 8/5 M-F w/JLAB Holidays ReBaseline | MECH ENG [160 h] | 11,947.2 |  |  |  |  |  | 2532140 | 0 | CHUDAKOV | 1 | 1 | D |  | S | EUGENE C | 11-006 | 11-026 | 13-007 |  | 13-015 | PR | 14-001 | ST | 12-021 | 12-054 | EJ |  |
| 2532130 | FDC/CDC Gas Systems Controls | 43d | 2013-12-17 | 2014-02-26 | 2562392a FS+21d, 2562392 FS+21d |  |  |  |  | 24d |  | 8/5 M-F w/JLAB Holidays ReBaseline | MECH ENG [120 h] | 8,960.4 |  |  |  |  |  | 2532130 | 0 | CHUDAKOV | 1 | 1 | D |  | S | EUGENE C | 11-006 | 11-026 | 13-007 |  | 13-015 | PR | 14-001 | ST | 12-021 |  | EJ | 12-040 |
| 2532180 | BIAS Control for Microscope | 62d | 2014-01-02 | 2014-03-31 | 2531350 |  |  |  |  | 128d |  | 8/5 M-F w/JLAB Holidays ReBaseline | SCIENTIST [160 h] | 12,028.8 |  |  |  |  |  | 2532180 | 0 | CHUDAKOV | 1 | 1 | D |  | S | EUGENE C | 11-006 | 11-026 |  |  | 13-015 | PR | 14-001 | ST | 12-021 |  | EJ | 12-040 |
| 2532155 | Cryo Target Controls | 50d | 2014-01-07 | 2014-03-18 | 9-140M FS+62d |  |  |  |  | 10d |  | 8/5 M-F w/JLAB Holidays ReBaseline | MECH ENG [200 h] | 14,934 |  |  |  |  |  | 2532155 | 0 | CHUDAKOV | 1 | 1 | D |  | S | EUGENE C | 11-006 | 11-026 |  |  | 13-015 | PR | 14-001 | ST | 12-021 |  | EJ | 12-040 |
| 2532200 | Vacuum System Controls (accel Grp) | 37d | 2014-01-10 | 2014-03-04 | 9-140M FS+65d |  |  |  |  | 20d | 9d | 8/5 M-F w/JLAB Holidays ReBaseline | ELEC ENG; COMP SCIENT [160 h] | 11,179.2 |  |  |  |  |  | 2532200 | 0 | CHUDAKOV | 1 | 1 | D |  | S | EUGENE C | 11-006 | 11-026 |  |  | 13-015 | PR | 14-001 | ST | 12-021 |  | EJ | 12-040 |
| 2532110 | Archiving Run Conditions | 181d | 2014-01-13 | 2014-09-26 | 9-140M FS+66d |  |  |  |  | 2d |  | 8/5 M-F w/JLAB Holidays ReBaseline | VISTNG USERS [600 h]; SCIENTIST [160 h] | 24,382.8 |  |  |  |  |  | 2532110 | 0 | CHUDAKOV | 1 | 1 | D |  | S | EUGENE C | 11-006 | 11-026 | 13-007 |  | 13-015 | PR | 14-001 | ST | 12-021 |  | EJ | 12-040 |
| 2532195 | Active collimator integration EPICS (Acceler grp) | 173d | 2014-01-15 | 2014-09-18 | 9-140M FS+68d |  |  |  |  | 8d |  | 8/5 M-F w/JLAB Holidays ReBaseline | COMP SCIENT [440 h] | 30,742.8 |  |  |  |  |  | 2532195 | 0 | CHUDAKOV | 1 | 1 | D |  | S | EUGENE C | 11-006 | 11-026 | 13-007 |  | 13-015 | PR | 14-001 | ST | 12-021 |  | EJ | 12-040 |
| 2532235 | Scaler Monitoring in EPICS | 179d | 2014-01-15 | 2014-09-26 | 9-140M FS+68d, 2562830a |  |  |  |  | 2d |  | 8/5 M-F w/JLAB Holidays ReBaseline | SCIENTIST [320 h] | 24,057.6 |  |  |  |  |  | 2532235 | 0 | CHUDAKOV | 1 | 1 | D |  | S | EUGENE C | 11-006 | 11-026 |  |  | 13-015 | PR | 14-001 | ST | 12-021 |  | EJ | 12-040 |
| 2532240 | Trigger Monitoring in EPICS | 179d | 2014-01-15 | 2014-09-26 | 9-140M FS+68d |  |  |  |  | 2d |  | 8/5 M-F w/JLAB Holidays ReBaseline | SCIENTIST [160 h] | 12,028.8 |  |  |  |  |  | 2532240 | 0 | CHUDAKOV | 1 | 1 | D |  | S | EUGENE C | 11-006 | 11-026 |  |  | 13-015 | PR | 14-001 | ST | 12-021 |  | EJ | 12-040 |
| 2532150 | FCAL Dark Room Controls | 42d | 2014-02-06 | 2014-04-04 | 9-140M FS+83d |  |  |  |  | 67d |  | 8/5 M-F w/JLAB Holidays ReBaseline | MECH ENG [160 h] | 11,947.2 |  |  |  |  |  | 2532150 | 0 | CHUDAKOV | 1 | 1 | D |  | S | EUGENE C | 11-006 | 11-026 | 13-007 |  | 13-015 | PR | 14-001 | ST | 12-021 |  | EJ | 12-040 |
| 2532090 | Event Display | 122d | 2014-03-04 | 2014-08-22 | 9-140M FS+100d |  |  |  |  | 26d |  | 8/5 M-F w/JLAB Holidays ReBaseline | CONTRB UNIV LBR [880 h]; SCIENTIST [80 h] | 6,014.4 |  |  |  |  |  | 2532090 | 0 | CHUDAKOV | 1 | 1 | D |  | S | EUGENE C | 11-006 | 11-026 | 13-007 |  | 13-015 | PR | 14-001 | ST | 12-021 |  | EJ |  |
| 2532220 | Debug EPICS Controls Sofware | 127d | 2014-03-18 | 2014-09-15 | 2532205a, 2532215a, 2532215, 2531165, 2532185, 2532190, 2532200, 2532205, 2531165a |  |  |  |  | 11d |  | 8/5 M-F w/JLAB Holidays ReBaseline | VISTNG USERS [200 h]; SCIENTIST [200 h] | 19,154 |  |  |  |  |  | 2532220 | 0 | CHUDAKOV | 1 | 1 | D |  | S | EUGENE C | 11-006 | 11-026 |  |  | 13-015 | PR | 14-001 | ST | 12-021 |  | EJ | 12-040 |
| 2532225 | Debug PLC Controls Sofware | 127d | 2014-04-02 | 2014-09-30 | 2532140, 2532150 FS-70d, 2532130, 2532145, 2532155, 2532135 |  |  |  |  | 0d |  | 8/5 M-F w/JLAB Holidays ReBaseline | SCIENTIST [40 h]; MECH ENG [200 h] | 17,941.2 |  |  |  |  |  | 2532225 | 0 | CHUDAKOV | 1 | 1 | D |  | S | EUGENE C | 11-006 | 11-026 |  |  | 13-015 | PR | 14-001 |  | 12-021 |  | EJ | 12-040 |
| 2532255 | Coherent Peak Alignment Software with Goniometer | 109d | 2014-04-15 | 2014-09-17 | 2532250a FS-10d, 2532250 |  |  |  |  | 9d |  | 8/5 M-F w/JLAB Holidays ReBaseline | SCIENTIST [200 h] | 15,036 |  |  |  |  |  | 2532255 | 0 | CHUDAKOV | 1 | 1 | D |  | S | EUGENE C | 11-006 | 11-026 |  |  | 13-015 | PR | 14-001 | ST | 12-021 |  | EJ | 12-040 |
| 2532060 | Debug DAQ software | 113d | 2014-04-22 | 2014-09-30 | 2532070, 2532040a, 2532055, 2532050, 2532050a, 2532040, 2532035, 2532035a, 2532015, 2532070a |  |  |  |  | 0d |  | 8/5 M-F w/JLAB Holidays ReBaseline | SCIENTIST [320 h] | 24,057.6 |  |  |  |  |  | 2532060 | 0 | CHUDAKOV | 1 | 1 | D |  | S | EUGENE C | 11-006 | 11-026 | 13-007F |  | 13-015 | PR | 14-001 |  | 12-021F | 12-054F | EJ |  |

Notes:
- 2532085: Steps: Develop "last event" paradigm and implement in RootSpy system; Develop non-GUI RootSpy archiver program (done); Add archived histogram comparison feature to RootSpy GUI; Implement mechansim for copying ROOT archives to tape silo
- 2532055: Steps: initial configuration for: Production physics data taking; initial configuration for: Individual detector calibration runs; initial configuration for: Debugging mode running (full FADC sample readout); initial configuration for: Cosmic data taking
- 2532100: Steps: Configure partitions on RAID disks; Write data transfer scripts; Implement warning and alarm scheme; Documentation
- 2532250: Steps: Backup/restore for test setups; Final backup/restore with MYA; Integration with CSS
- 2532245: Steps: collect runcontrol rates; evaluate whether additional evnt plugin rates are necessary; collect rates from JANA processes; integrate with operator monitoring/alarm system
- 2532030: Steps: install CODA3 on the central file system in the Hall-D; test full path with EMU systems (EB, ER, RAID disk); write documentation for CODA3 installation
- 2532115: Steps: Establish repository for archiving COOL configurations; Write script to commit changes at appropriate CODA transitions and integrate into CODA system
- 2532145: Steps: CDC temperature; ST temperature; BCAL temperature; FDC temperature
- 2532190: Steps: Program PS magnet power supply; Program sweeping magnet PS; Documenation
- 2532250a: Steps: Backup/restore for test setups; Final backup/restore with MYA; Integration with CSS
- 2532185: Steps: EPICS support for NMR; EPICS support for tagger magnet PS; EDM control GUIs
- 2532140: Steps: FDC Chiller; BCAL Chiller; Target Chiller; Documentation
- 2532130: Steps: Program MFCs communication; Program pressure censor readout; Program valve control; Documentation
- 2532180: Steps: Install EPICS on SBCs; EPICS driver for microscope LV using API; Integration of UCONN and Jlab software; LV controls GUIs
- 2532155: Steps: Serial control of temperature controllers/monitors; Refrigerator control; Relay controls programming; Pressure sensor readout
- 2532200: Steps: Program valves/sensors in tagger hall; Program pumps in tagger hall; Program valves/sensors in Hall D; Program pupms in Hall D
- 2532110: Steps: Design and implement a conditions database; Design and implement a run database; Form lists of relevant parameters to store with each CODA state transition; Write scripts to gather relevant info. And enter into run DB. Integrate into CODA configuration; Document system
- 2532195: Steps: Collect information on the hardware; Intall EPICS IOC on the chassis; Configure EPICS records database
- 2532235: Steps: Develop EPICS support for discriminator scaler readout; Develop EPICS support for FADC250 scalers; Port Struck scaler EPICS driver to Linux
- 2532240: Steps: Develop EPICS support for the readout of FADC250 parameters; Develop EPICS support for the readout of CTP/SSP/GTP parameters
- 2532150: Steps: Program light and humidity sensors; Program relays; Documentation
- 2532090: Steps: Re-evaluate requirements for online event display and identify missing components in hdview2/ded; Implment missing features in hdview2/ded or begin work on new event viewer; Complete work on final online event viewer and deploy in Hall-D counting house with documentation
- 2532220: Steps: Debug voltage control software; Debug interface with PLC chassis; Debug motor controls; Debug scaler readout

| ID | WBS | Activity | Type | Duration | Start | Finish | Predecessors | Complete | Remaining | Planned start | Planned finish | Total float | Free float | Calendar | Resources | Cost | Actual cost | LOE Divider | LOE Multiplier | Calculated Remaining Total Cost | MONTHLY EV COST | RESP - Responsibility | STRT%COMP for CM EVM | FNSH%COMP for CM EVM | HALL D Related Milestones | CR 07-024 | EVMS Reporting Codes | CAM RESPONSIBLE | CR 11-006 | CR 11-026 | Duplications | Activities with Steps | CR 09-012 | CR 11-049 | CR 12-021 | MARCH!!! | Remaining Material Cost Based on % Compl | Claimed Material Cost Based on % Complet | Initial Claimed Material Calc | Claimed Material Divider | Inter Project Link (IPL) | Advance Purchase Plan > 500K | CR 08-016 | CR 08-036 | 12 GEV MAJOR PROCUREMENT CATAGORY | CR 10-024 | CR 10-042 | CR 12-014 | CR 12-047 | CR 08-035 | CR 09-014 | CR 12-044 | LOE % Pre Calc | LOE % | CR 12-001 | CR 09-045 | Phil Dev | CR 08-052 | CR 12-054 | ReBaseline Actuals Adjustment | Original Activity ID Rebaseline | BOE Labor | CR 13-015 | Post Rebaseline | Obligated Prior to Rebaseline | PRIOR MONTH EV COST | CR 14-001 | CR 13-007 |
| --- | --- | --- | --- | --- | --- | --- | --- | --- | --- | --- | --- | --- | --- | --- | --- | --- | --- | --- | --- | --- | --- | --- | --- | --- | --- | --- | --- | --- | --- | --- | --- | --- | --- | --- | --- | --- | --- | --- | --- | --- | --- | --- | --- | --- | --- | --- | --- | --- | --- | --- | --- | --- | --- | --- | --- | --- | --- | --- | --- | --- | --- | --- | --- | --- | --- | --- | --- | --- |
|  | 3 | **1.5.3.3 OFFLINE COMPUTING** |  |  |  |  |  |  |  |  |  |  |  |  |  |  |  |  |  |  |  |  |  |  |  |  |  |  |  |  |  |  |  |  |  |  |  |  |  |  |  |  |  |  |  |  |  |  |  |  |  |  |  |  |  |  |  |  |  |  |  |  |  |  |  |  |  |  |
|  | 4 | **1.5.4 ELECTRONICS** |  |  | 2008-11-06 | 2014-09-30 |  |  |  |  |  |  |  |  |  |  |  |  |  |  |  |  |  |  |  |  |  |  |  |  |  |  |  |  |  |  |  |  |  |  |  |  |  |  |  |  |  |  |  |  |  |  |  |  |  |  |  |  |  |  |  |  |  |  |  |  |  |  |
|  | 1 | **1.5.4.1 FADC** |  |  | 2009-10-01 | 2014-09-30 |  |  |  |  |  |  |  |  |  |  |  |  |  |  |  |  |  |  |  |  |  |  |  |  |  |  |  |  |  |  |  |  |  |  |  |  |  |  |  |  |  |  |  |  |  |  |  |  |  |  |  |  |  |  |  |  |  |  |  |  |  |  |
| 1541010E |  | FY10 Travel (FADC) |  | 248d | 2009-10-01 A | 2010-09-30 A | 9-100M | 100% |  |  |  |  |  |  | TRAVEL | 574.67 |  | 100 | 100 | 0 | 574.66511 | CHUDAKOV | 1 | 1 | D | 07-024 | E | EUGENE C | 11-006 | 11-026 |  |  |  |  |  |  |  |  |  |  |  |  |  |  |  |  |  |  |  |  |  |  |  |  |  |  |  |  |  |  |  |  |  |  |  |  |  |  |
| 1541075 |  | Implement DC Features Extraction Algorithms (FADC) |  | 785d | 2009-10-26 A | 2013-08-30 A | 9-120M FS-1000d, 1541070 FS-1000d | 100% |  | 2009-10-26 | 2012-12-31 |  |  |  | SCIENTIST [880 h]; ELEC DES [560 h] | 88,137.51 | 89,052.74 |  |  | 22605.6 | 90422.4 | CHUDAKOV | 1 | 1 | D | 07-024 | S | EUGENE C | 11-006 | 11-026 | DUP | ST | 09-012 | 11-049 | 12-021F | XX |  |  |  |  |  |  |  |  |  |  |  |  |  |  |  |  |  |  |  |  |  |  |  |  |  |  |  |  |  |  |  |  |
| 1541029 |  | Vend Fab First Article fADCs for PMTs (FADC) |  | 282d | 2010-06-07 A | 2011-07-25 A | 9-100M FS+166d | 100% |  |  |  |  |  |  | PROCUREMENT>$50K 69; PROCUREMENT<$50K 60 | 140,000 |  |  |  | 0 | 140000 | CHUDAKOV | 1 | 1 | D | 07-024 | D | EUGENE C | 11-006 | 11-026 |  |  |  | 11-049 |  |  | 0 | 140000 | 14000000 | 100 | IPL | APP | 08-016 | 08-036 | 541B | 10-024 | 10-042 | 12-014 | 12-047F |  |  |  |  |  |  |  |  |  |  |  |  |  |  |  |  |  |  |  |
| 1541084 |  | First Articles fADCs for DCs (FADC) (IPL 5541170) |  | 108d | 2010-06-28 A | 2010-11-30 A | 9-100M FS+185d | 100% |  |  |  |  |  |  | PROCUREMENT<$50K 60 NO ESCALATION FY11; PROCUREMENT>$50K 69 NO ESCALATION FY11 | 80,000 |  |  |  | 0 | 80000 | CHUDAKOV | 1 | 1 | D | 07-024 | D | EUGENE C | 11-006 | 11-026 | DUP |  |  | 11-049 | 12-021F |  | 0 | 80000 | 8000000 | 100 | IPL | APP |  |  | 541A |  | 10-042 |  |  | 08-035 | 09-014 | 12-044F |  |  |  |  |  |  |  |  |  |  |  |  |  |  |  |  |
| 1541005 |  | Calibrate ADC gain and linearity (FADC) 1543016 |  | 611d | 2010-10-01 A | 2013-07-15 A | 9-110M | 100% |  | 2010-10-01 | 2013-03-25 |  |  |  | SCIENTIST [440 h]; ELEC TECH [880 h] | 69,451.22 | 69,754.89 |  |  | 33873.4 | 67746.8 | CHUDAKOV | 1 | 1 | D | 07-024 | H | EUGENE C | 11-006 | 11-026 | DUP |  | 09-012 | 11-049 |  |  |  |  |  |  |  |  |  |  |  |  |  | 12-014 | 12-047F |  |  |  |  |  |  |  |  |  |  |  |  |  |  |  |  |  |  |  |
| 1541011E |  | FY11 Travel (FADC) |  | 248d | 2010-10-01 A | 2011-09-30 A | 1541010E | 100% |  |  |  |  |  |  | TRAVEL | 593 |  | 100 | 100 | 0 | 593 | CHUDAKOV | 1 | 1 | D | 07-024 | E | EUGENE C | 11-006 | 11-026 |  |  |  |  |  |  |  |  |  |  |  |  |  |  |  |  |  |  |  |  |  |  | 8.46774193 | 91.53225806 |  |  |  |  |  |  |  |  |  |  |  |  |  |  |
| 1541010 |  | Develop gain correction database for FADC in FPGA (FADC) 1543016 |  | 590d | 2010-11-01 A | 2013-08-30 A | 1541005 FS-250d, 9-110M | 100% |  | 2010-11-01 | 2013-03-25 |  |  |  | SCIENTIST [480 h] | 33,702.54 | 33,905.2 |  |  | 16423.2 | 32846.4 | CHUDAKOV | 1 | 1 | D | 07-024 | H | EUGENE C | 11-006 | 11-026 | DUP |  | 09-012 | 11-049 |  |  |  |  |  |  |  |  |  |  |  |  |  | 12-014 | 12-047F |  |  |  |  |  |  |  |  |  |  |  |  |  |  |  |  |  |  |  |
| 1541030 |  | fADC250 - Full Single-Crate Acceptance Test (FADC) |  | 28d | 2011-07-25 A | 2011-08-31 A | 1541015 FS-325d, 9-110M FS+165d, 1541029 FS-40d | 100% |  |  |  |  |  |  | ELEC ENG [160 h]; ELEC TECH [160 h] | 17,784 | 17,784 |  |  | 0 | 17784 | CHUDAKOV | 1 | 1 | D | 07-024 | H | EUGENE C | 11-006 | 11-026 |  |  |  | 11-049 |  |  |  |  |  |  | IPL | APP | 08-016 | 08-036 | 541B | 10-024 | 10-042 | 12-014 | 12-047F |  |  |  |  |  |  |  |  |  |  |  |  |  |  |  |  |  |  |  |
| 1541040 |  | fADC250 - Production Procurement Support (FADC) FY11 |  | 79.36d | 2011-07-25 A | 2011-11-14 A | 1541030 FS-70d | 100% |  |  |  |  |  |  | ELEC ENG [95.48 h] | 6,608.54 | 6,608.54 |  |  | 0 | 6528.9224 | CHUDAKOV | 1 | 1 | D | 07-024 | H | EUGENE C | 11-006 | 11-026 |  |  |  | 11-049 |  |  |  |  |  |  |  |  |  |  |  |  |  | 12-014 | 12-047F |  |  |  |  |  | 12-001 |  |  |  |  |  |  |  |  |  |  |  |  |  |
| 1541040a |  | fADC250 - Production Procurement Support (FADC) FY12 |  | 80d | 2011-07-25 A | 2011-11-14 A | 1541040 FS-25d | 100% |  |  |  |  |  |  | ELEC ENG [64.52 h] | 4,466.38 | 4,466.38 |  |  | 0 | 4552.5312 | CHUDAKOV | 1 | 1 | D | 07-024 | H | EUGENE C | 11-006 | 11-026 |  |  |  | 11-049 |  |  |  |  |  |  |  |  |  |  |  |  |  | 12-014 | 12-047F |  |  |  |  |  | 12-001 |  |  |  |  |  |  |  |  |  |  |  |  |  |
| 1541085 |  | fADC125 - Procurement Support Pre Production Modules (QTY 3) |  | 160d | 2011-07-25 A | 2012-03-19 A | 9-110M FS+101d, 1541084 | 100% |  |  |  |  |  |  | ELEC TECH [160 h] | 6,994.16 | 6,994.16 |  |  | 0 | 6843.2 | CHUDAKOV | 1 | 1 | D | 07-024 | H | EUGENE C | 11-006 | 11-026 | DUP |  |  | 11-049 | 12-021F |  |  |  |  |  | IPL | APP |  |  | 541A |  | 10-042 |  |  | 08-035 | 09-014 | 12-044F |  |  |  |  |  |  |  |  |  |  |  |  |  |  |  |  |
| 1541012E |  | FY12 Travel (FADC) |  | 247d | 2011-10-03 A | 2012-09-28 A | 1541011E | 100% |  |  |  |  |  |  | TRAVEL | 611.92 |  | 100 | 100 | 0 | 611.92 | CHUDAKOV | 1 | 1 | D | 07-024 | E | EUGENE C | 11-006 | 11-026 |  |  |  |  |  |  |  |  |  |  |  |  |  |  |  |  |  |  |  |  |  |  | 7.69230769 | 92.3076923 |  |  |  |  |  |  |  |  |  |  |  |  |  |  |
| 1541112 |  | Test stand for testing/acceptance of FADC125 |  | 282d | 2011-12-01 A | 2013-02-11 A | 9-120M, 1541100 FS-160d | 100% |  | 2011-12-01 | 2013-01-25 |  |  |  | ELEC ENG [200 h]; SCIENTIST [200 h] | 28,476.56 | 28,501.24 |  |  | 0 | 28234 | CHUDAKOV | 1 | 1 | D | 07-024 | H | EUGENE C | 11-006 | 11-026 | DUP |  | 09-012 | 11-049 | 12-021F | XX |  |  |  |  |  |  |  |  |  |  |  |  |  |  |  | 12-044F |  |  |  | 09-045 |  |  |  |  |  |  |  |  |  |  |  |  |
| 1541045 |  | fADC250 - Production (FADC) |  | 220d | 2012-01-03 A | 2012-11-12 A | 9-120M FS+59d, 1541040a | 100% |  |  |  |  |  |  | PROCUREMENT<$50K 60 NO ESCALATION; PROCUREMENT>$50K 69 NO ESCALATION | 1,446,246.9 |  |  |  | 0 | 1446246.9 | CHUDAKOV | 1 | 1 | D | 07-024 | D | EUGENE C | 11-006 | 11-026 |  |  |  | 11-049 |  |  | 0 | 1446246.9 | 144624690 | 100 |  |  |  |  |  |  |  | 12-014 | 12-047F |  |  |  |  |  |  |  | MP |  |  |  |  |  |  |  |  |  |  |  |
| 1541065 |  | Assemble DC Logic/Signal Analyzers (FADC) (in 6 GeV also) |  | 9d | 2012-02-01 A | 2012-02-13 A | 9-120M FS+61d | 100% |  |  |  |  |  |  |  |  |  |  |  |  | 0 | CHUDAKOV | 1 | 1 | D | 07-024 | Z | EUGENE C | 11-006 | 11-026 | DUP |  | 09-012 | 11-049 | 12-021F |  |  |  |  |  |  |  |  |  |  |  |  |  |  |  |  |  |  |  |  |  |  | 08-052 |  |  |  |  |  |  |  |  |  |  |
| 1541085b |  | fADC125 - Pre Production Modules (QTY 3) |  | 53d | 2012-02-01 A | 2012-04-16 A | 1541085 FS-80d, 9-120M FS+43d | 100% |  |  |  |  |  |  | PROCUREMENT<$50K 60 | 12,750 |  |  |  | 0 | 12750 | CHUDAKOV | 1 | 1 | D | 07-024 | D | EUGENE C | 11-006 | 11-026 | DUP |  |  | 11-049 | 12-021 |  | 0 | 12750 | 1275000 | 100 |  | APP |  |  | 541A |  | 10-042 |  |  | 08-035 | 09-014 | 12-044F |  |  |  |  |  |  |  |  |  |  |  |  |  |  |  |  |
| 1541125 |  | fADC125 - Procurement Support (FADC) |  | 91d | 2012-02-01 A | 2012-06-11 A | 9-120M | 100% |  |  |  |  |  |  | ELEC TECH [80 h] | 3,530.4 | 3,530.4 |  |  | 0 | 3530.4 | CHUDAKOV | 1 | 1 | D | 07-024 | H | EUGENE C | 11-006 | 11-026 | DUP |  |  | 11-049 | 12-021F |  |  |  |  |  | IPL | APP |  |  | 541A |  | 10-042 |  |  | 08-035 | 09-014 | 12-044F |  |  |  |  |  |  |  |  |  |  |  |  |  |  |  |  |
| 1541070 |  | Implement DC CODA Libraries (FADC) (in 6 GeV also) |  | 5d | 2012-02-13 A | 2012-02-20 A | 1541065, 9-120M | 100% |  | 2012-02-13 | 2012-02-17 |  |  |  |  |  |  |  |  |  | 0 | CHUDAKOV | 1 | 1 | D | 07-024 | Z | EUGENE C | 11-006 | 11-026 | DUP |  | 09-012 | 11-049 | 12-021F |  |  |  |  |  |  |  |  |  |  |  |  |  |  |  |  |  |  |  |  |  |  | 08-052 |  |  |  |  |  |  |  |  |  |  |
| 1541080 |  | Dry Run of Test DC Procedures (FADC) (in 6 GeV also) |  | 5d | 2012-02-20 A | 2012-02-27 A | 9-120M, 1541075 | 100% |  | 2012-02-21 | 2012-02-27 |  |  |  |  |  |  |  |  |  | 0 | CHUDAKOV | 1 | 1 | D | 07-024 | Z | EUGENE C | 11-006 | 11-026 | DUP |  | 09-012 | 11-049 | 12-021F |  |  |  |  |  |  |  |  |  |  |  |  |  |  |  |  |  |  |  |  |  |  | 08-052 |  |  |  |  |  |  |  |  |  |  |
| 1541015 |  | Implement PMT Features Extraction Algorithms (FADC) |  | 243d | 2012-04-02 A | 2013-07-15 A | 1541010 FS-200d, 9-110M | 100% |  | 2012-04-02 | 2013-03-25 |  |  |  | SCIENTIST [176 h]; ELEC DES [112 h] | 18,359.6 | 18,432.79 |  |  | 8763.04 | 17526.08 | CHUDAKOV | 1 | 1 | D | 07-024 | H | EUGENE C | 11-006 | 11-026 | DUP |  | 09-012 | 11-049 |  |  |  |  |  |  |  |  |  |  |  |  |  | 12-014 | 12-047F |  |  |  |  |  |  |  |  |  |  |  |  |  |  |  |  |  |  |  |
| 1541100 |  | fADC125 - Test Pre Production Modules (QTY 3) |  | 64d | 2012-04-09 A | 2012-07-09 A | 1541085b FS-213d | 100% |  |  |  |  |  |  | ELEC ENG [80 h]; ELEC TECH [200 h] | 14,470.8 | 14,470.8 |  |  | 0 | 14470.8 | CHUDAKOV | 1 | 1 | D | 07-024 | H | EUGENE C | 11-006 | 11-026 |  |  |  | 11-049 | 12-021F |  |  |  |  |  |  |  |  |  |  |  |  |  |  |  | 09-014 | 12-044F |  |  |  |  |  |  |  |  |  |  |  |  |  |  |  |  |
| 1541130 |  | Vend Fab FADC125 Peg Points #1 and # 2 Board Samples Mezzanine and Main |  | 85d | 2012-07-14 A | 2012-11-12 A | 9-120M FS+192d, 1541125 | 100% |  | 2012-07-16 | 2012-11-12 |  |  |  |  |  |  |  |  |  | 0 | CHUDAKOV | 1 | 1 | D | 07-024 | D | EUGENE C | 11-006 | 11-026 | DUP |  |  | 11-049 | 12-021 |  |  |  |  |  |  | APP |  |  | 541A |  | 10-042 |  |  | 08-035 | 09-014 | 12-044 |  |  |  |  |  |  |  |  |  |  |  |  |  |  |  |  |
| 1541132 |  | Vend Fab FADC125 Peg Points #3 and # 4 First Article Mezzanine and Main (Qty. 1 Each) |  | 123d | 2012-07-14 A | 2013-03-11 A | 1541130 FS-36d | 100% |  | 2012-07-16 | 2013-01-15 |  |  |  | PROCUREMENT<$50K 60 NO ESCALATION | 13,763.77 |  |  |  | 0 | 13763.77 | CHUDAKOV | 1 | 1 | D | 07-024 | D | EUGENE C | 11-006 | 11-026 | DUP |  |  | 11-049 | 12-021 | XX | 0 | 13763.77 | 1376377 | 100 |  | APP |  |  | 541A |  | 10-042 |  |  | 08-035 | 09-014 | 12-044 |  |  |  |  |  |  |  |  |  |  |  |  |  |  |  |  |
| 1541134 |  | Vend Fab FADC125 Peg Points #5 and # 6 Production Units Mezzanine and Main (Qty. 50 Each) |  | 175d | 2012-07-14 A | 2013-04-15 A | 1541132 FS-78d | 100% |  | 2012-07-16 | 2013-04-01 |  |  |  | PROCUREMENT<$50K 60 NO ESCALATION; PROCUREMENT>$50K 69 NO ESCALATION | 155,746.5 |  |  |  | 0 | 155746.5 | CHUDAKOV | 1 | 1 | D | 07-024 | D | EUGENE C | 11-006 | 11-026 | DUP |  |  | 11-049 | 12-021 |  | 0 | 155746.5 | 15574650 | 100 |  | APP |  |  | 541A |  | 10-042 |  |  | 08-035 | 09-014 | 12-044 |  |  |  |  | MP |  |  |  |  |  |  |  |  |  |  |  |
| 1541136 |  | Vend Fab FADC125 Peg Points #7 and # 8 Production Units Mezzanine and Main (Qty. 50 Each) |  | 175d | 2012-07-14 A | 2013-05-13 A | 1541134 FS-114d | 100% |  | 2012-07-16 | 2013-04-01 |  |  |  | PROCUREMENT>$50K 69 NO ESCALATION | 155,746.5 |  |  |  | 0 | 155746.5 | CHUDAKOV | 1 | 1 | D | 07-024 | D | EUGENE C | 11-006 | 11-026 | DUP |  |  | 11-049 | 12-021 |  | 0 | 155746.5 | 15574650 | 100 |  | APP |  |  | 541A |  | 10-042 |  |  | 08-035 | 09-014 | 12-044 |  |  |  |  | MP |  |  |  |  |  |  |  |  |  |  |  |
| 1541138 |  | Vend Fab FADC125 Peg Points #9 and # 10 Production Units Mezzanine and Main (Qty. 50 Each) |  | 199d | 2012-07-14 A | 2013-06-17 A | 1541136 FS-114d | 100% |  | 2012-07-16 | 2013-05-03 |  |  |  | PROCUREMENT>$50K 69 NO ESCALATION | 155,746.5 |  |  |  | 0 | 155746.5 | CHUDAKOV | 1 | 1 | D | 07-024 | D | EUGENE C | 11-006 | 11-026 | DUP |  |  | 11-049 | 12-021 |  | 0 | 155746.5 | 15574650 | 100 |  | APP |  |  | 541A |  | 10-042 |  |  | 08-035 | 09-014 | 12-044 |  |  |  |  | MP |  |  |  |  |  |  |  |  |  |  |  |
| 1541143 |  | Vend Fab FADC125 Peg Points #11 and # 12 Production Units Mezzanine and Main (Qty. 66 Each) |  | 199d | 2012-07-14 A | 2013-08-30 A | 1541138 FS-135d | 100% |  | 2012-07-16 | 2013-05-03 |  |  |  | PROCUREMENT>$50K 69 NO ESCALATION | 205,585.38 |  |  |  | 102792.69 | 205585.38 | CHUDAKOV | 1 | 1 | D | 07-024 | D | EUGENE C | 11-006 | 11-026 | DUP |  |  | 11-049 | 12-021 |  | 0 | 205585.38 | 20558538 | 100 |  | APP |  |  | 541A |  | 10-042 |  |  | 08-035 | 09-014 | 12-044 |  |  |  |  | MP |  |  |  |  |  |  |  |  |  |  |  |
| 1541057 |  | UMASS - fADC250 - Production Test (FADC) Rediness Review |  | 10d | 2012-09-17 A | 2012-09-28 A | 1543016a, 1541045 FS-48d, 1543125 | 100% |  |  |  |  |  |  | ELEC ENG [8 h]; SCIENTIST [8 h] | 1,129.36 | 1,129.36 |  |  | 0 | 1129.36 | CHUDAKOV | 1 | 1 | D | 07-024 | U | EUGENE C | 11-006 | 11-026 |  |  |  | 11-049 |  |  |  |  |  |  |  |  |  |  |  |  |  |  | 12-047 |  |  |  |  |  |  |  |  |  |  |  |  |  |  |  |  |  |  |  |
| 1541013E |  | FY13 Travel (FADC) |  | 58d | 2012-10-01 A | 2012-12-31 A | 1541012E | 100% |  | 2012-10-01 | 2012-12-21 |  |  |  | TRAVEL | 158.16 |  | 100 | 100 | 0 | 158.16 | CHUDAKOV | 1 | 1 | D | 07-024 | E | EUGENE C | 11-006 | 11-026 |  |  |  |  |  |  |  |  |  |  |  |  |  |  |  |  |  |  |  |  |  |  | 25.86206896 | 74.13793103 |  |  |  |  |  |  |  |  |  |  |  |  |  |  |
| 1541058M |  | UMASS - Begin fADC250 - Production Test (FADC) | milestone | 0d | 2012-10-22 A | 2012-10-22 A | 1541057 FS+22d | 100% |  | 2012-11-01 | 2012-11-01 |  |  |  |  |  |  |  |  |  | 0 | CHUDAKOV | 1 | 1 | D | 07-024 | M | EUGENE C | 11-006 | 11-026 |  |  |  | 11-049 |  |  |  |  |  |  |  |  |  |  |  |  |  |  | 12-047 |  |  |  |  |  |  |  |  |  |  |  |  |  |  |  |  |  |  |  |
| 1541059 |  | UMASS - fADC250 - Production Test (FADC) |  | 105d | 2012-10-22 A | 2013-02-11 A | 1541058M | 100% |  | 2012-10-22 | 2013-03-29 |  |  |  | PROCUREMENT<$50K 60 NO ESCALATION | 43,349.84 |  |  |  | 0 | 43349.84 | CHUDAKOV | 1 | 1 | D | 07-024 | D | EUGENE C | 11-006 | 11-026 |  |  |  | 11-049 |  |  | 0 | 43349.84 | 4334984 | 100 |  |  |  |  |  |  |  |  | 12-047 |  |  |  |  |  |  |  |  |  |  |  |  |  |  |  |  |  |  |  |
| 1541145 |  | fADC125 - Test (Qty 217) (FADC) |  | 112d | 2013-05-01 A | 2013-08-30 A | 1541143 FS-63d, 1541112, 9-130M FS+144d, 1541132 | 100% |  | 2013-06-03 | 2013-11-07 |  |  |  | ELEC TECH [489.87 h]; ELEC ENG [27.6 h] | 24,511.82 | 24,318.24 |  |  | 14590.8983421 | 24318.238091 | CHUDAKOV | 1 | 1 | D | 07-024 | U | EUGENE C | 11-006 | 11-026 |  |  |  | 11-049 | 12-021 |  |  |  |  |  |  |  |  |  |  |  |  |  |  |  | 09-014 | 12-044 |  |  |  |  |  |  | 12-054 |  |  |  |  |  |  |  |  |  |
| 1541060 |  | Assy of fADC PMT as part of Trigger (FADC) |  | 65d | 2013-07-01 A | 2013-07-15 A | 9-130M FS+110d, 1541045 | 100% |  | 2013-08-01 | 2013-10-31 |  |  |  | ELEC DES [240 h] | 12,649.77 | 12,508.8 |  |  | 12508.8 | 12508.8 | CHUDAKOV | 1 | 1 | D | 07-024 | U | EUGENE C | 11-006 | 11-026 |  |  |  | 11-049 |  |  |  |  |  |  |  |  |  |  |  |  |  |  |  |  |  |  |  |  |  |  |  |  |  |  |  |  |  |  |  |  |  |  |
| 1541120 |  | fADC125 - Full Single-Crate Acceptance Test (FADC) |  | 41d | 2013-08-30 A | 2013-08-30 A | 1541145 FS-100d, 9-130M FS+80d | 100% |  | 2013-09-03 | 2013-10-29 |  |  |  | ELEC TECH [160 h]; ELEC ENG [160 h] | 19,244.96 | 18,936 |  |  | 18936 | 18936 | CHUDAKOV | 1 | 1 | D | 07-024 | S | EUGENE C | 11-006 | 11-026 |  | ST |  | 11-049 | 12-021 |  |  |  |  |  |  |  |  |  |  |  |  |  |  |  | 09-014 | 12-044 |  |  |  |  |  |  | 12-054 |  |  |  |  |  |  |  |  |  |
| 1541150 |  | Re-Baseline Actuals Adjustment |  | 1d | 2013-08-30 A | 2013-08-30 A |  | 100% |  | 2013-09-03 | 2013-09-03 |  |  |  | PROCUREMENT>$50K 69 NO ESCALATION | -60,191.42 |  |  |  |  |  |  |  |  |  |  |  |  |  |  |  |  |  |  |  |  |  |  |  | 100 |  |  |  |  |  |  |  |  |  |  |  |  |  |  |  |  |  |  |  | ADJ |  |  |  |  |  |  |  |  |
| 2541000 |  | Vend Fab FADC-125 (Previously Obligated) |  | 210d | 2013-09-03 A | 2014-07-10 | 9-130M FS+228d |  | 167d | 2013-10-01 | 2014-08-07 | 57d |  | 8/5 M-F w/JLAB Holidays ReBaseline | PROCUREMENT<$50K 60 NO ESCALATION FY14 | 43,318.25 |  |  |  |  | 0 | CHUDAKOV | 1 | 1 | D | 07-024 | U | EUGENE C | 11-006 | 11-026 | DUP |  | 09-012 | 11-049 |  |  | 43318.25 | 0 | 0 | 100 |  |  |  |  |  |  |  | 12-014 | 12-047F |  |  |  |  |  |  |  |  |  |  |  | 2541015 | PE | 13-015 | PR | OB |  |  |  |
| 2541015 |  | Rework of Production FADC Modules (FE) FY13 |  | 20d | 2013-09-03 A | 2014-07-10 | 9-130M FS+228d | 30% | 167d | 2013-10-01 | 2013-10-28 | 57d | 33d | 8/5 M-F w/JLAB Holidays ReBaseline | ELEC ENG [17.78 h]; ELEC TECH [35.55 h] | 3,006.21 | 606.72 |  |  |  | 0 | CHUDAKOV | 1 | 1 | D | 07-024 | U | EUGENE C | 11-006 | 11-026 | DUP |  | 09-012 | 11-049 |  |  |  |  |  |  |  |  |  |  |  |  |  | 12-014 | 12-047F |  |  |  |  |  |  |  |  |  |  |  | 2541015 | PE | 13-015 | PR |  | 874.0253727 |  |  |
| 2541015a |  | Rework of Production FADC Modules (FE) FY14 |  | 190d | 2013-09-03 A | 2014-07-10 | 2541015 FS-200d | 30% | 167d | 2013-10-01 | 2014-07-10 | 57d |  | 8/5 M-F w/JLAB Holidays ReBaseline | ELEC ENG [168.89 h]; ELEC TECH [337.78 h] | 28,560.99 | 5,764.24 |  |  |  | 0 | CHUDAKOV | 1 | 1 | D | 07-024 | U | EUGENE C | 11-006 | 11-026 | DUP |  | 09-012 | 11-049 |  |  |  |  |  |  |  |  |  |  |  |  |  | 12-014 | 12-047F |  |  |  |  |  |  |  |  |  |  |  | 2541015 | PE | 13-015 | PR |  | 8568.29637 | 14-001 |  |
| 2541145 |  | fADC125 - Test (Qty 217) (FADC) FY13 |  | 20d | 2013-09-03 A | 2013-09-23 A | 9-130M FS+228d | 100% |  | 2013-10-01 | 2013-10-28 |  |  | 8/5 M-F w/JLAB Holidays ReBaseline | ELEC TECH [10.97 h]; ELEC ENG [1.29 h] | 612.42 | 593.51 |  |  |  | 0 | CHUDAKOV | 1 | 1 | D | 07-024 | U | EUGENE C | 11-006 | 11-026 |  |  |  | 11-049 | 12-021 |  |  |  |  |  |  |  |  |  |  |  |  |  |  |  | 09-014 | 12-044 |  |  |  |  |  |  | 12-054 |  | 2541145 | EJ | 13-015 | PR |  | 593.513044 |  |  |
| 2541145a |  | fADC125 - Test (Qty 217) (FADC) FY14 |  | 42d | 2013-09-03 A | 2013-09-23 A | 2541145 | 100% |  | 2013-10-01 | 2013-11-27 |  |  | 8/5 M-F w/JLAB Holidays ReBaseline | ELEC TECH [23.03 h]; ELEC ENG [2.71 h] | 1,285.76 | 1,246.09 |  |  |  | 0 | CHUDAKOV | 1 | 1 | D | 07-024 | U | EUGENE C | 11-006 | 11-026 |  |  |  | 11-049 | 12-021 |  |  |  |  |  |  |  |  |  |  |  |  |  |  |  | 09-014 | 12-044 |  |  |  |  |  |  | 12-054 |  | 2541145 | EJ | 13-015 | PR |  | 1285.767199 | 14-001 |  |
| 2541150 |  | FADC125 Production firmware development FY13 (Hall D EE) |  | 20d | 2013-09-03 A | 2013-12-20 | 9-130M FS+228d | 35% | 33.75d | 2013-10-01 | 2013-10-28 | 1.25d |  | 8/5 M-F w/JLAB Holidays ReBaseline | ELEC ENG [72.96 h] | 5,481.48 | 3,026.95 |  |  |  | 1593.66528 | CHUDAKOV | 1 | 1 | D |  | S | EUGENE C |  |  |  | ST |  |  |  |  |  |  |  |  |  |  |  |  |  |  |  |  |  |  |  |  |  |  |  |  |  |  |  |  | 2541150 | EJ | 13-015 | PR |  | 265.61088 |  | 13-007 |
| 2541150a |  | FADC125 Production firmware development FY14 (Hall D EE) |  | 57d | 2013-09-03 A | 2013-12-20 | 2541150 FS-60d | 35% | 34d | 2013-10-01 | 2013-12-20 | 1d |  | 8/5 M-F w/JLAB Holidays ReBaseline | ELEC ENG [207.04 h] | 15,554.92 | 8,561.75 |  |  |  | 4666.47456 | CHUDAKOV | 1 | 1 | D |  | S | EUGENE C |  |  |  | ST |  |  |  |  |  |  |  |  |  |  |  |  |  |  |  |  |  |  |  |  |  |  |  |  |  |  |  |  | 2541150 | EJ | 13-015 | PR |  | 777.74576 | 14-001 | 13-007 |
| 2541120 |  | fADC125 - Full Single-Crate Acceptance Test (FADC) FY13 |  | 16d | 2013-11-01 | 2013-11-22 | 2541145 FS-58d, 2541145a FS-58d |  |  |  |  | 140d | 0d | 8/5 M-F w/JLAB Holidays ReBaseline | ELEC TECH [35.07 h]; ELEC ENG [35.07 h] | 4,282.75 |  |  |  |  | 0 | CHUDAKOV | 1 | 1 | D | 07-024 | U | EUGENE C | 11-006 | 11-026 |  |  |  | 11-049 | 12-021 |  |  |  |  |  |  |  |  |  |  |  |  |  |  |  | 09-014 | 12-044 |  |  |  |  |  |  | 12-054 |  | 2541120 | PE | 13-015 | PR |  |  |  |  |
| 2541152 |  | Algorithm Development for DC FADC125 FY13 |  | 20d | 2013-11-01 | 2013-12-02 | 9-130M FS+228d |  |  |  |  | 0d |  | 8/5 M-F w/JLAB Holidays ReBaseline | SCIENTIST [23.43 h] | 1,761.47 |  |  |  |  | 0 | CHUDAKOV | 1 | 1 | D |  | S | EUGENE C |  |  |  |  |  |  |  |  |  |  |  |  |  |  |  |  |  |  |  |  |  |  |  |  |  |  |  |  |  |  |  |  | 2541152 | PE | 13-015 | PR |  |  |  | 13-007 |
| 2541120a |  | fADC125 - Full Single-Crate Acceptance Test (FADC) FY14 |  | 57d | 2013-11-25 | 2014-02-26 | 2541120, 2541145a FS-58d |  |  |  |  | 141d | 1d | 8/5 M-F w/JLAB Holidays ReBaseline | ELEC TECH [124.93 h]; ELEC ENG [124.93 h] | 15,256.45 |  |  |  |  | 0 | CHUDAKOV | 1 | 1 | D | 07-024 | U | EUGENE C | 11-006 | 11-026 |  |  |  | 11-049 | 12-021 |  |  |  |  |  |  |  |  |  |  |  |  |  |  |  | 09-014 | 12-044 |  |  |  |  |  |  | 12-054 |  | 2541120 | PE | 13-015 | PR |  |  | 14-001 |  |
| 2541155 |  | FADC EE Hardware/software support in FY14 (Hall D EE) |  | 205d | 2013-12-02 | 2014-09-30 | 2541150a FS-16d, 9-140M FS+42d, 2541150 FS-16d |  |  |  |  | 0d |  | 8/5 M-F w/JLAB Holidays ReBaseline | ELEC ENG [800 h] | 60,104 |  | 100 | 100 |  | 0 | CHUDAKOV | 1 | 1 | D |  | E | EUGENE C |  |  |  |  |  |  |  |  |  |  |  |  |  |  |  |  |  |  |  |  |  |  |  |  | 100 | 0 |  |  |  |  |  |  | 2541155 | PE | 13-015 | PR |  |  | 14-001 | 13-007 |
| 2541152a |  | Algorithm Development for DC FADC125 FY14 |  | 176d | 2013-12-03 | 2014-08-20 | 2541152 |  |  |  |  | 0d |  | 8/5 M-F w/JLAB Holidays ReBaseline | SCIENTIST [256.57 h] | 19,288.93 |  |  |  |  | 0 | CHUDAKOV | 1 | 1 | D |  | S | EUGENE C |  |  |  |  |  |  |  |  |  |  |  |  |  |  |  |  |  |  |  |  |  |  |  |  |  |  |  |  |  |  |  |  | 2541152 | PE | 13-015 | PR |  |  | 14-001 | 13-007 |
| 2541154 |  | Code Deployment and Full Readout Tests FADC125 |  | 124d | 2014-04-07 | 2014-09-30 | 2541152 FS-96d, 2541152a FS-96d |  |  |  |  | 0d |  | 8/5 M-F w/JLAB Holidays ReBaseline | SCIENTIST [240 h] | 18,043.2 |  |  |  |  | 0 | CHUDAKOV | 1 | 1 | D |  | S | EUGENE C |  |  |  |  |  |  |  |  |  |  |  |  |  |  |  |  |  |  |  |  |  |  |  |  |  |  |  |  |  |  |  |  | 2541154 | EJ | 13-015 | PR |  |  | 14-001 | 13-007 |

Notes:
- 1541075: Steps: FPGA Programming for VME/Processor/Front end (IUCF) (done); Fabrication of 3 FADC Units (IUCF) (done); Testing and Evaluation of Basic Functions (IUCF) (done); Documentation (IUCF) (done); Testing with FDC and CDC (done); Develop and Test Timing extraction (done); Implement/Test Timing extraction (done); Engineering (1 Crate) Run and Test (done)
- 1541029: Explanation: IPL from 6 GeV 5541140M
- 1541084: Explanation: IPL from 6 GeV 5541170
- 1541030: Explanation: IPL from 6 GeV 5541140M
- 1541085: Explanation: IPL from 6 GeV 5541170
- 1541125: Explanation: IPL from 6 GeV 5541170
- 1541120: Steps: fADC125 - Full Single-Crate Acceptance Test (FADC) (done)
- 2541150: Steps: Layout of the FPGA mapping (done); Develop, install and test Front-end and Main FPGA firmware; Install and test FPGA firmware for VME (done); Integrate, Test and deploy code
- 2541150a: Steps: Layout of the FPGA mapping (done); Develop, install and test Front-end and Main FPGA firmware; Install and test FPGA firmware for VME (done); Integrate, Test and deploy code

| ID | WBS | Activity | Type | Duration | Start | Finish | Predecessors | Complete | Remaining | Planned start | Planned finish | Total float | Free float | Calendar | Resources | Cost | Actual cost | Remaining Material Cost Based on % Compl | Claimed Material Cost Based on % Complet | Initial Claimed Material Calc | Claimed Material Divider | Calculated Remaining Total Cost | MONTHLY EV COST | RESP - Responsibility | STRT%COMP for CM EVM | FNSH%COMP for CM EVM | HALL D Related Milestones | CR 07-024 | CR 08-016 | EVMS Reporting Codes | CAM RESPONSIBLE | CR 08-038 | CR 09-002 | Duplications | CR 09-012 | CR 11-006 | CR 11-026 | CR 11-049 | CR 12-021 | CR 12-054 | CR 08-052 | LOE % Pre Calc | LOE % | LOE Divider | LOE Multiplier | CR 09-045 | CR 10-024 | MARCH!!! | CR 12-047 | CR 12-053 | ReBaseline Actuals Adjustment | Original Activity ID Rebaseline | PRIOR MONTH EV COST | BOE Labor | CR 13-015 | Post Rebaseline | Activities with Steps | CR 13-007 | CR 14-001 |
| --- | --- | --- | --- | --- | --- | --- | --- | --- | --- | --- | --- | --- | --- | --- | --- | --- | --- | --- | --- | --- | --- | --- | --- | --- | --- | --- | --- | --- | --- | --- | --- | --- | --- | --- | --- | --- | --- | --- | --- | --- | --- | --- | --- | --- | --- | --- | --- | --- | --- | --- | --- | --- | --- | --- | --- | --- | --- | --- | --- |
|  | 2 | **1.5.4.2 TDC** |  |  | 2008-11-06 | 2014-08-06 |  |  |  |  |  |  |  |  |  |  |  |  |  |  |  |  |  |  |  |  |  |  |  |  |  |  |  |  |  |  |  |  |  |  |  |  |  |  |  |  |  |  |  |  |  |  |  |  |  |  |  |  |  |
| 1542025 |  | Phase 1 Proc TDCs (TDC) |  | 73d | 2008-11-06 A | 2009-03-02 A | 9-090M FS+23d | 100% |  |  |  |  |  |  | PROCUREMENT>$50K 69 NO ESCALATION FY10; PROCUREMENT<$50K 60 NO ESCALATION FY10 | 199,281.6 |  | 0 | 199281.6 | 19928160 | 100 | 0 | 199281.6 | CHUDAKOV | 1 | 1 | D | 07-024 | 08-016 | P | EUGENE C | 08-038 | 09-002 | DUP | 09-012 | 11-006 | 11-026 | 11-049 | 12-021F | 12-054F |  |  |  |  |  |  |  |  |  |  |  |  |  |  |  |  |  |  |  |
| 1542010 |  | Measure cross talk for CFD & TDC (TDC) |  | 15d | 2010-09-06 A | 2010-09-27 A | 1542005, 9-110M | 100% |  | 2010-09-07 | 2010-09-27 |  |  |  | SCIENTIST [171.04 h]; ELEC TECH [313.56 h] | 24,338.72 | 24,338.72 |  |  |  |  | 0 | 25115.2284 | CHUDAKOV | 1 | 1 | D | 07-024 |  | H | EUGENE C |  |  | DUP | 09-012 | 11-006 | 11-026 | 11-049 | 12-021F | 12-054F |  |  |  |  |  |  |  |  |  |  |  |  |  |  |  |  |  |  |  |
| 1542005 |  | Assemble Logic/Signal Analyzers (TDC) (in 6 GeV also) |  | 5.5d | 2010-09-13 A | 2010-09-20 A | 1234180M, 9-110M | 100% |  |  |  |  |  |  |  |  |  |  |  |  |  |  | 0 | CHUDAKOV | 1 | 1 | D | 07-024 |  | Z | EUGENE C |  |  | DUP | 09-012 | 11-006 | 11-026 | 11-049 | 12-021F | 12-054F | 08-052 |  |  |  |  |  |  |  |  |  |  |  |  |  |  |  |  |  |  |
| 1542011E |  | FY11 Travel (TDC) |  | 248d | 2010-10-01 A | 2011-09-30 A | 9-110M | 100% |  |  |  |  |  |  | TRAVEL | 857.18 |  |  |  |  |  | 0 | 857.18 | CHUDAKOV | 1 | 1 | D | 07-024 |  | E | EUGENE C |  |  |  |  |  | 11-026 |  |  |  |  | 8.46774193 | 91.53225806 | 100 | 100 |  |  |  |  |  |  |  |  |  |  |  |  |  |  |
| 1542025a |  | F1TDC - First Article Procurement Support (TDC) |  | 357d | 2011-01-05 A | 2012-06-11 A | 1542010, 1234180M, 1542025, 9-110M FS+59d | 100% |  |  |  |  |  |  | ELEC ENG [160 h]; ELEC TECH [240 h] | 21,525.23 | 21,525.23 |  |  |  |  | 0 | 21205.6 | CHUDAKOV | 1 | 1 | D | 07-024 | 08-016 | H | EUGENE C | 08-038 | 09-002 | DUP |  | 11-006 | 11-026 | 11-049 | 12-021F | 12-054F |  |  |  |  |  | 09-045 | 10-024 |  |  |  |  |  |  |  |  |  |  |  |  |
| 1542026 |  | F1TDC - Parts (TDC) |  | 339d | 2011-02-01 A | 2012-06-11 A | 1542025a FS-83d | 100% |  |  |  |  |  |  | PROCUREMENT<$50K 60 | 40,000 |  | 0 | 40000 | 4000000 | 100 | 0 | 40000 | CHUDAKOV | 1 | 1 | D |  |  | D | EUGENE C |  |  | DUP |  | 11-006 | 11-026 | 11-049 | 12-021F | 12-054F |  |  |  |  |  |  |  |  |  |  |  |  |  |  |  |  |  |  |  |
| 1542012E |  | FY12 Travel (TDC) |  | 247d | 2011-10-03 A | 2012-09-28 A | 1542011E | 100% |  |  |  |  |  |  | TRAVEL | 884.52 |  |  |  |  |  | 0 | 884.52 | CHUDAKOV | 1 | 1 | D | 07-024 |  | E | EUGENE C |  |  |  |  |  | 11-026 |  |  |  |  | 7.69230769 | 92.3076923 | 100 | 100 |  |  |  |  |  |  |  |  |  |  |  |  |  |  |
| 1542027 |  | F1TDC - First Article Fab V2 (QTY 2) (TDC) |  | 11d | 2011-12-03 A | 2011-12-19 A | 1542026 FS-50d | 100% |  | 2011-12-05 | 2011-12-19 |  |  |  | PROCUREMENT<$50K 60 | 2,000 |  | 0 | 2000 | 200000 | 100 | 0 | 2000 | CHUDAKOV | 1 | 1 | D |  |  | D | EUGENE C |  |  | DUP |  | 11-006 | 11-026 | 11-049 | 12-021F | 12-054F |  |  |  |  |  |  |  |  |  |  |  |  |  |  |  |  |  |  |  |
| 1542015 |  | Dry Run of Test Procedures TDC |  | 180d | 2012-02-01 A | 2012-10-15 A | 1542010 FS+280d | 100% |  |  |  |  |  |  | ELEC ENG [400 h] | 28,279 | 28,279 |  |  |  |  | 0 | 27352 | CHUDAKOV | 1 | 1 | D | 07-024 |  | H | EUGENE C |  |  | DUP |  | 11-006 | 11-026 |  | 12-021F |  |  |  |  |  |  |  |  |  |  |  |  |  |  |  |  |  |  |  |  |
| 1542030 |  | F1TDC - First Article Assembly V2 (QTY 2) (TDC) |  | 53d | 2012-02-01 A | 2012-04-16 A | 1542027 | 100% |  |  |  |  |  |  | PROCUREMENT<$50K 60 NO ESCALATION FY12 | 2,500 |  | 0 | 2500 | 250000 | 100 | 0 | 2500 | CHUDAKOV | 1 | 1 | D | 07-024 |  | D | EUGENE C |  |  | DUP | 09-012 | 11-006 | 11-026 | 11-049 | 12-021F | 12-054F |  |  |  |  |  | 09-045 |  |  |  |  |  |  |  |  |  |  |  |  |  |
| 1542030a |  | F1TDC - First Article Test V2 (QTY 2) (TDC) |  | 59d | 2012-04-15 A | 2012-07-09 A | 1542030, 9-120M | 100% |  | 2012-04-16 | 2012-07-09 |  |  |  | ELEC TECH [136 h]; ELEC ENG [96 h] | 12,775.44 | 12,775.44 |  |  |  |  | 0 | 12775.44 | CHUDAKOV | 1 | 1 | D | 07-024 |  | H | EUGENE C |  |  | DUP | 09-012 | 11-006 | 11-026 | 11-049 | 12-021 | 12-054F |  |  |  |  |  | 09-045 |  |  |  |  |  |  |  |  |  |  |  |  |  |
| 1542036 |  | Test stand for testing/acceptance of F1TDC |  | 216d | 2012-05-01 A | 2013-04-15 A | 1542015 FS-40d, 9-120M, 1542010 | 100% |  | 2012-05-01 | 2013-03-15 |  |  |  | ELEC ENG [200 h]; SCIENTIST [200 h] | 28,692.34 | 28,731.46 |  |  |  |  | 0 | 28234 | CHUDAKOV | 1 | 1 | D | 07-024 |  | H | EUGENE C |  |  | DUP | 09-012 | 11-006 | 11-026 |  | 12-021F |  |  |  |  |  |  | 09-045 |  |  |  |  |  |  |  |  |  |  |  |  |  |
| 1542031 |  | F1TDC - First Article Fab V3 (QTY 2) (TDC) |  | 25d | 2012-06-02 A | 2012-07-09 A | 1542030 | 100% |  | 2012-06-05 | 2012-07-09 |  |  |  | PROCUREMENT<$50K 60 | 2,063.8 |  | 0 | 2063.8 | 206380 | 100 | 0 | 2063.8 | CHUDAKOV | 1 | 1 | D |  |  | D | EUGENE C |  |  | DUP |  | 11-006 | 11-026 | 11-049 | 12-021F | 12-054F |  |  |  |  |  |  |  |  |  |  |  |  |  |  |  |  |  |  |  |
| 1542040 |  | F1TDC - Production Procurement Prep (TDC) |  | 55d | 2012-07-02 A | 2012-09-17 A | 1542037 FS-150d | 100% |  |  |  |  |  |  | ELEC TECH [160 h] | 7,060.8 | 7,060.8 |  |  |  |  | 0 | 7286.4 | CHUDAKOV | 1 | 1 | D | 07-024 |  | H | EUGENE C |  |  | DUP | 09-012 | 11-006 | 11-026 | 11-049 | 12-021 | 12-054F |  |  |  |  |  | 09-045 |  |  |  |  |  |  |  |  |  |  |  |  |  |
| 1542031a |  | F1TDC - First Article Assembly V3 (QTY 2) (TDC) |  | 6d | 2012-07-15 A | 2012-07-23 A | 1542031 | 100% |  | 2012-07-16 | 2012-07-23 |  |  |  | PROCUREMENT<$50K 60 | 2,579.75 |  | 0 | 2579.75 | 257975 | 100 | 0 | 2579.75 | CHUDAKOV | 1 | 1 | D | 07-024 |  | D | EUGENE C |  |  | DUP | 09-012 | 11-006 | 11-026 | 11-049 | 12-021F | 12-054F |  |  |  |  |  | 09-045 |  |  |  |  |  |  |  |  |  |  |  |  |  |
| 1542031b |  | F1TDC - First ArticleTest V3 (QTY 2) (TDC) |  | 10d | 2012-09-03 A | 2012-09-17 A | 9-120M, 1542031a FS-15d | 100% |  | 2012-09-04 | 2012-09-17 |  |  |  | ELEC TECH [136 h]; ELEC ENG [96 h] | 12,775.44 | 12,775.44 |  |  |  |  | 0 | 12775.44 | CHUDAKOV | 1 | 1 | D | 07-024 |  | H | EUGENE C |  |  | DUP | 09-012 | 11-006 | 11-026 | 11-049 | 12-021 | 12-054F |  |  |  |  |  | 09-045 |  |  |  |  |  |  |  |  |  |  |  |  |  |
| 1542032 |  | F1TDC - First Article Fab (QTY 18) (TDC) |  | 85d | 2012-09-03 A | 2013-02-11 A | 1542031a, 1542030, 9-120M FS+35d, 1542031b, 1542030a | 100% |  | 2012-09-04 | 2013-01-10 |  |  |  | PROCUREMENT<$50K 60 | 8,667.96 |  | 0 | 8667.96 | 866796 | 100 | 0 | 8667.96 | CHUDAKOV | 1 | 1 | D |  |  | D | EUGENE C |  |  | DUP |  | 11-006 | 11-026 | 11-049 | 12-021 | 12-054F |  |  |  |  |  |  |  | XX |  |  |  |  |  |  |  |  |  |  |  |
| 1542035 |  | F1TDC - First Article Assembly (QTY 18) (TDC) |  | 85d | 2012-09-03 A | 2013-02-11 A | 1542032 FS-70d | 100% |  | 2012-09-04 | 2013-01-10 |  |  |  | PROCUREMENT<$50K 60 NO ESCALATION FY13 | 11,970.04 |  | 0 | 11970.04 | 1197004 | 100 | 0 | 11970.04 | CHUDAKOV | 1 | 1 | D | 07-024 |  | D | EUGENE C |  |  | DUP | 09-012 | 11-006 | 11-026 | 11-049 | 12-021 | 12-054 |  |  |  |  |  | 09-045 |  | XX |  |  |  |  |  |  |  |  |  |  |  |
| 1542042 |  | F1TDC - Production (TDC) |  | 138d | 2012-09-10 A | 2013-04-15 A | 1542040 | 100% |  | 2012-09-10 | 2013-04-03 |  |  |  | PROCUREMENT<$50K 60 NO ESCALATION FY14; PROCUREMENT>$50K 69 NO ESCALATION FY14 |  |  |  |  |  |  | 0 | 0 | CHUDAKOV | 1 | 1 | D |  |  | D | EUGENE C |  |  | DUP |  | 11-006 | 11-026 | 11-049 | 12-021 | 12-054 |  |  |  |  |  |  |  |  |  |  |  |  |  |  |  |  |  |  |  |
| 1542013E |  | FY13 Travel (TDC) |  | 58d | 2012-10-01 A | 2012-12-31 A | 1542012E | 100% |  | 2012-10-01 | 2012-12-21 |  |  |  | TRAVEL | 226.99 |  |  |  |  |  | 0 | 226.99 | CHUDAKOV | 1 | 1 | D | 07-024 |  | E | EUGENE C |  |  |  |  |  | 11-026 |  |  |  |  | 25.86206896 | 74.13793103 | 100 | 100 |  |  |  |  |  |  |  |  |  |  |  |  |  |  |
| 1542045 |  | UMASS - F1TDC - Production Test (TDC) Readiness Review |  | 5d | 2012-11-06 A | 2012-11-12 A | 1542042 FS-97d, 1542035a FS-50d | 100% |  |  |  |  |  |  | ELEC ENG [8 h]; SCIENTIST [8 h] | 1,165.36 | 582.48 |  |  |  |  | 0 | 1165.36 | CHUDAKOV | 1 | 1 | D | 07-024 |  | H | EUGENE C |  |  |  | 09-012 | 11-006 | 11-026 | 11-049 | 12-021 | 12-054 |  |  |  |  |  | 09-045 |  |  | 12-047 |  |  |  |  |  |  |  |  |  |  |
| 1542050M |  | UMASS - Begin F1TDC - Production Test (F1TDC) | milestone | 0d | 2012-11-13 A | 2012-11-13 A | 1542045 | 100% |  | 2012-12-13 | 2012-12-13 |  |  |  |  |  |  |  |  |  |  |  | 0 | CHUDAKOV | 1 | 1 | D | 07-024 |  | M | EUGENE C |  |  |  |  | 11-006 | 11-026 | 11-049 |  | 12-054 |  |  |  |  |  |  |  |  | 12-047 |  |  |  |  |  |  |  |  |  |  |
| 1542055 |  | UMASS - F1TDC - Production Test (F1TDC) |  | 94d | 2012-11-13 A | 2013-05-13 A | 1542050M, 1542050M SS | 100% |  | 2012-11-13 | 2013-04-05 |  |  |  | PROCUREMENT<$50K 60 NO ESCALATION | 43,349.84 |  | 0 | 43349.84 | 4334984 | 100 | 0 | 0 | CHUDAKOV | 1 | 1 | D | 07-024 |  | D | EUGENE C |  |  |  |  | 11-006 | 11-026 | 11-049 |  | 12-054 |  |  |  |  |  |  |  |  | 12-047 |  |  |  |  |  |  |  |  |  |  |
| 1542035a |  | F1TDC - First ArticleTest V2 (QTY 18) (TDC) |  | 10d | 2013-02-11 A | 2013-02-23 A | 1542035 | 100% |  | 2013-04-10 | 2013-04-23 |  |  |  | ELEC ENG [56 h]; ELEC TECH [272 h] | 16,464.24 | 16,464.24 |  |  |  |  | 0 | 16464.24 | CHUDAKOV | 1 | 1 | D | 07-024 |  | H | EUGENE C |  |  | DUP | 09-012 | 11-006 | 11-026 | 11-049 | 12-021 | 12-054 |  |  |  |  |  | 09-045 |  | XX | 12-047F | 12-053 |  |  |  |  |  |  |  |  |  |
| 1542037 |  | F1TDC - Full Single-Crate Acceptance Test (TDC) |  | 58d | 2013-04-15 A | 2013-08-30 A | 1542035, 1542036 | 100% |  | 2013-05-24 | 2013-08-15 |  |  |  | ELEC ENG [160 h]; ELEC TECH [160 h] | 18,936 | 18,936 |  |  |  |  | 9468 | 18936 | CHUDAKOV | 1 | 1 | D |  |  | H | EUGENE C |  |  | DUP |  | 11-006 | 11-026 | 11-049 | 12-021 | 12-054 |  |  |  |  |  |  |  |  |  | 12-053 |  |  |  |  |  |  |  |  |  |
| 1542060 |  | Re-Baseline Actuals Adjustment |  | 1d | 2013-08-30 A | 2013-08-30 A |  | 100% |  | 2013-09-03 | 2013-09-03 |  |  |  | PROCUREMENT>$50K 69 NO ESCALATION | 468,084.23 |  | 0 | 468084.23 | 46808423 | 100 |  | 468084.23 |  |  |  |  |  |  |  |  |  |  |  |  |  |  |  |  |  |  |  |  |  |  |  |  |  |  |  | ADJ |  |  |  |  |  |  |  |  |
| 2542037 |  | F1TDC - Full Single-Crate Acceptance Test (TDC) |  | 14d | 2013-09-03 A | 2013-09-18 A | 9-130M FS+228d | 100% |  | 2013-10-01 | 2013-10-18 |  |  | 8/5 M-F w/JLAB Holidays ReBaseline | ELEC ENG [128 h]; ELEC TECH [128 h] | 15,631.36 | 15,148.8 |  |  |  |  |  | 0 | CHUDAKOV | 1 | 1 | D |  |  | U | EUGENE C |  |  | DUP |  | 11-006 | 11-026 | 11-049 | 12-021 | 12-054 |  |  |  |  |  |  |  |  |  | 12-053 |  | 2542037 | 15148.8 | PE | 13-015 | PR |  |  |  |
| 2542070 |  | F1TDC develop firmware FY13 |  | 20d | 2013-09-03 A | 2013-10-21 A | 9-130M FS+228d | 100% |  | 2013-10-01 | 2013-10-28 |  |  | 8/5 M-F w/JLAB Holidays ReBaseline | ELEC ENG [55.31 h] | 4,155.44 | 4,138.9 |  |  |  |  |  | 3221.69688 | CHUDAKOV | 1 | 1 | D | 07-024 |  | S | EUGENE C |  |  |  |  | 11-006 | 11-026 | 11-049 |  | 12-054 |  |  |  |  |  |  |  |  | 12-047 |  |  | 2542070 | 805.42422 | EJ | 13-015 | PR | ST | 13-007 |  |
| 2542070a |  | F1TDC develop firmware FY14 |  | 61d | 2013-09-03 A | 2013-10-21 A | 2542070 FS-75d | 100% |  | 2013-10-01 | 2014-01-07 |  |  | 8/5 M-F w/JLAB Holidays ReBaseline | ELEC ENG [168.69 h] | 12,673.68 | 12,598.42 |  |  |  |  |  | 10138.94376 | CHUDAKOV | 1 | 1 | D | 07-024 |  | S | EUGENE C |  |  |  |  | 11-006 | 11-026 | 11-049 |  | 12-054 |  |  |  |  |  |  |  |  | 12-047 |  |  | 2542070 | 2534.73594 | EJ | 13-015 | PR | ST | 13-007 | 14-001 |
| 2542085 |  | Rework of Production F1TDC modules |  | 134d | 2013-09-03 A | 2014-04-30 | 9-140M | 40% | 118d | 2013-10-10 | 2014-04-30 | 106d |  | 8/5 M-F w/JLAB Holidays ReBaseline | ELEC TECH [400 h] | 18,796 | 4,948 |  |  |  |  |  | 3759.2 | CHUDAKOV | 1 | 1 | D | 07-024 |  | U | EUGENE C |  |  |  |  | 11-006 | 11-026 | 11-049 |  | 12-054 |  |  |  |  |  |  |  |  | 12-047 |  |  | 2542085 | 3759.2 | EJ | 13-015 | PR |  | 13-007 | 14-001 |
| 2542090 |  | F1TDC EE Hardware/Software Support FY14 |  | 186d | 2013-11-01 | 2014-08-06 | 2542070a, 2542070 |  |  |  |  | 38d |  | 8/5 M-F w/JLAB Holidays ReBaseline | ELEC ENG [360 h] | 27,046.8 |  |  |  |  |  |  | 0 | CHUDAKOV | 1 | 1 | D | 07-024 |  | E | EUGENE C |  |  |  |  | 11-006 | 11-026 | 11-049 |  | 12-054 |  | 100 | 0 | 100 | 100 |  |  |  | 12-047 |  |  | 2542090 |  | PE | 13-015 | PR |  | 13-007 | 14-001 |
| 2542075 |  | FPGA Coding, Hardware & Firmware Integration Tests F1TDC |  | 44d | 2013-11-11 | 2014-01-24 | 2542070 FS+14d, 2542070a FS+14d |  |  |  |  | 130d | 0d | 8/5 M-F w/JLAB Holidays ReBaseline | ELEC ENG [240 h] | 18,031.2 |  |  |  |  |  |  | 0 | CHUDAKOV | 1 | 1 | D | 07-024 |  | S | EUGENE C |  |  |  |  | 11-006 | 11-026 | 11-049 |  | 12-054 |  |  |  |  |  |  |  |  | 12-047 |  |  | 2542075 |  | EJ | 13-015 | PR |  | 13-007 | 14-001 |
| 2542080 |  | Code Deployment and Full Readout Tests F1TDC |  | 39d | 2014-02-03 | 2014-03-27 | 2542075 FS+5d |  |  |  |  | 130d |  | 8/5 M-F w/JLAB Holidays ReBaseline | SCIENTIST [160 h] | 12,028.8 |  |  |  |  |  |  | 0 | CHUDAKOV | 1 | 1 | D | 07-024 |  | S | EUGENE C |  |  |  |  | 11-006 | 11-026 | 11-049 |  | 12-054 |  |  |  |  |  |  |  |  | 12-047 |  |  | 2542080 |  | EJ | 13-015 | PR |  | 13-007 | 14-001 |

Notes:
- 1542025a: Explanation: IPL From 6 GeV BIA / 5542200M
- 1542026: Explanation: IPL From 6 GeV BIA / 5542200M
- 1542027: Explanation: IPL From 6 GeV BIA / 5542200M
- 1542031: Explanation: IPL From 6 GeV BIA / 5542200M
- 1542032: Explanation: IPL From 6 GeV BIA / 5542200M
- 1542042: Explanation: IPL From 6 GeV BIA / 5542200M
- 1542037: Explanation: IPL From 6 GeV BIA / 5542200M
- 2542037: Explanation: IPL From 6 GeV BIA / 5542200M
- 2542070: Steps: Develop FPGA firmware (done); Install and test F1 and Main FPGA firmware (done); Install and test FPGA firmware for VME (done); Integrate, Test and deploy code (done)
- 2542070a: Steps: Develop FPGA firmware (done); Install and test F1 and Main FPGA firmware (done); Install and test FPGA firmware for VME (done); Integrate, Test and deploy code (done)

| ID | WBS | Activity | Duration | Start | Finish | Predecessors | Complete | Remaining | Planned start | Planned finish | Total float | Free float | Calendar | Resources | Cost | Actual cost | LOE Divider | LOE Multiplier | Calculated Remaining Total Cost | MONTHLY EV COST | RESP - Responsibility | STRT%COMP for CM EVM | FNSH%COMP for CM EVM | HALL D Related Milestones | CR 07-024 | EVMS Reporting Codes | CAM RESPONSIBLE | CR 11-006 | CR 11-026 | CR 12-053 | Duplications | CR 09-012 | CR 12-021 | LOE % Pre Calc | LOE % | CR 08-052 | CR 07-027 | CR 12-001 | MARCH!!! | Remaining Material Cost Based on % Compl | Claimed Material Cost Based on % Complet | Initial Claimed Material Calc | Claimed Material Divider | CR 11-049 | CR 12-055 | Inter Project Link (IPL) | CR 10-024 | Activities with Steps | CR 12-054 | ReBaseline Actuals Adjustment | Original Activity ID Rebaseline | PRIOR MONTH EV COST | CR 12-047 | BOE Procurement | CR 13-015 | Post Rebaseline | Obligated Prior to Rebaseline | BOE Labor | CR 14-001 | BOE Expenses |
| --- | --- | --- | --- | --- | --- | --- | --- | --- | --- | --- | --- | --- | --- | --- | --- | --- | --- | --- | --- | --- | --- | --- | --- | --- | --- | --- | --- | --- | --- | --- | --- | --- | --- | --- | --- | --- | --- | --- | --- | --- | --- | --- | --- | --- | --- | --- | --- | --- | --- | --- | --- | --- | --- | --- | --- | --- | --- | --- | --- | --- |
|  | 3 | **1.5.4.3 TRIGGER** |  | 2009-10-01 | 2014-09-30 |  |  |  |  |  |  |  |  |  |  |  |  |  |  |  |  |  |  |  |  |  |  |  |  |  |  |  |  |  |  |  |  |  |  |  |  |  |  |  |  |  |  |  |  |  |  |  |  |  |  |  |  |  |  |  |
| 1543010E |  | FY10 Travel (TRIGR) | 248d | 2009-10-01 A | 2010-09-30 A | 9-100M | 100% |  |  |  |  |  |  | TRAVEL | 1,149.33 |  | 100 | 100 | 0 | 1149.33022 | CHUDAKOV | 1 | 1 | D | 07-024 | E | EUGENE C | 11-006 | 11-026 | 12-053F |  |  |  |  |  |  |  |  |  |  |  |  |  |  |  |  |  |  |  |  |  |  |  |  |  |  |  |  |  |  |
| 1543015 |  | Implement Features Extraction Algorithms | 21d | 2010-09-01 A | 2010-09-30 A | 1543010 | 100% |  |  |  |  |  |  | CONTRB UNIV LBR [440 h] |  |  |  |  |  | 0 | CHUDAKOV | 1 | 1 | D |  | Z | EUGENE C | 11-006 | 11-026 |  | DUP | 09-012 | 12-021F |  |  |  |  |  |  |  |  |  |  |  |  |  |  |  |  |  |  |  |  |  |  |  |  |  |  |  |
| 1543011E |  | FY11 Travel (TRIGR) | 248d | 2010-10-01 A | 2011-09-30 A | 1543010E | 100% |  |  |  |  |  |  | TRAVEL | 1,185.99 |  | 100 | 100 | 0 | 1185.99 | CHUDAKOV | 1 | 1 | D | 07-024 | E | EUGENE C | 11-006 | 11-026 | 12-053F |  |  |  | 8.46774193 | 91.53225806 |  |  |  |  |  |  |  |  |  |  |  |  |  |  |  |  |  |  |  |  |  |  |  |  |  |
| 1543005 |  | Assemble Logic/Signal Analyzers for Energy Sum Tests (Trigger) | 19d | 2011-02-01 A | 2011-02-28 A | 9-110M, 1234180M | 100% |  |  |  |  |  |  | CONTRB UNIV LBR [440 h] |  |  |  |  |  | 0 | CHUDAKOV | 1 | 1 | D |  | Z | EUGENE C | 11-006 | 11-026 |  | DUP | 09-012 | 12-021F |  |  |  |  |  |  |  |  |  |  |  |  |  |  |  |  |  |  |  |  |  |  |  |  |  |  |  |
| 1543010 |  | Implement CODA Libraries for Energy Sum (Trigger) (in 6 GeV also) | 19d | 2011-02-01 A | 2011-02-28 A | 1543005 | 100% |  |  |  |  |  |  |  |  |  |  |  |  | 0 | CHUDAKOV | 1 | 1 | D | 07-024 | Z | EUGENE C | 11-006 | 11-026 |  | DUP | 09-012 | 12-021F |  |  | 08-052 |  |  |  |  |  |  |  |  |  |  |  |  |  |  |  |  |  |  |  |  |  |  |  |  |
| 1543140 |  | Develop trigger algorithms FY11 | 452d | 2011-03-01 A | 2013-07-15 A | 9-110M FS+59d | 100% |  | 2011-03-01 | 2012-12-17 |  |  |  | SCIENTIST [428.5 h] | 30,059.5 | 30,333.31 |  |  | 14661.1275 | 29322.255 | CHUDAKOV | 1 | 1 | D | 07-024 | H | EUGENE C | 11-006 | 11-026 |  |  |  | 12-021F |  |  |  | 07-027 | 12-001 | XX |  |  |  |  |  |  |  |  |  |  |  |  |  |  |  |  |  |  |  |  |  |
| 1543140a |  | Develop trigger algorithms FY12 (Hall D grp) | 452d | 2011-03-01 A | 2013-08-30 A | 1543140 FS-205d | 100% |  | 2011-03-01 | 2012-12-17 |  |  |  | SCIENTIST [131.5 h] | 9,224.79 | 9,323.83 |  |  | 4642.6075 | 9285.215 | CHUDAKOV | 1 | 1 | D | 07-024 | H | EUGENE C | 11-006 | 11-026 |  |  |  | 12-021F |  |  |  | 07-027 | 12-001 | XX |  |  |  |  |  |  |  |  |  |  |  |  |  |  |  |  |  |  |  |  |  |
| 1543125 |  | Procument equipment for testing FADC250 | 177d | 2011-04-01 A | 2011-12-12 A | 1543120 FS-93d | 100% |  |  |  |  |  |  | PROCUREMENT<$50K 60 | 7,000 |  |  |  | 0 | 7000 | CHUDAKOV | 1 | 1 | D | 07-024 | D | EUGENE C | 11-006 | 11-026 |  |  |  |  |  |  |  |  |  |  | 0 | 7000 | 700000 | 100 | 11-049 |  |  |  |  |  |  |  |  |  |  |  |  |  |  |  |  |
| 1543120 |  | Prepare test stand for testing/acceptance of FADC250 | 16d | 2011-04-04 A | 2011-04-25 A | 9-110M FS+143d | 100% |  |  |  |  |  |  | ELEC ENG [63.6 h] | 4,348.97 | 4,348.97 |  |  | 0 | 4348.968 | CHUDAKOV | 1 | 1 | D | 07-024 | H | EUGENE C | 11-006 | 11-026 |  |  |  |  |  |  |  | 07-027 |  |  |  |  |  |  | 11-049 |  |  |  |  |  |  |  |  |  |  |  |  |  |  |  |  |
| 1543050 |  | Preparing procument of SD boards | 164d | 2011-05-16 A | 2012-01-16 A | 9-110M FS+146d | 100% |  | 2011-05-16 | 2012-01-13 |  |  |  | ELEC ENG [160 h] | 11,083.3 | 11,083.3 |  |  | 0 | 10940.8 | CHUDAKOV | 1 | 1 | D |  | H | EUGENE C | 11-006 | 11-026 |  | DUP | 09-012 | 12-021F |  |  |  |  |  |  |  |  |  |  | 11-049 |  |  |  |  |  |  |  |  |  |  |  |  |  |  |  |  |
| 1543035 |  | Preparing procument TI-D boards | 71d | 2011-05-23 A | 2011-08-31 A | 9-110M | 100% |  |  |  |  |  |  | ELEC ENG [160 h] | 10,940.8 | 10,940.8 |  |  | 0 | 10940.8 | CHUDAKOV | 1 | 1 | D | 07-024 | H | EUGENE C | 11-006 | 11-026 |  |  |  | 12-021F |  |  |  | 07-027 |  |  |  |  |  |  | 11-049 |  |  |  |  |  |  |  |  |  |  |  |  |  |  |  |  |
| 1543080 |  | Preparing procument of GTP boards FY11 | 430d | 2011-05-23 A | 2013-02-11 A | 9-110M | 100% |  | 2011-05-23 | 2013-02-15 |  |  |  | ELEC ENG [69.57 h] | 4,909.54 | 4,907.84 |  |  | 0 | 4757.1966 | CHUDAKOV | 1 | 1 | D | 07-024 | H | EUGENE C | 11-006 | 11-026 |  |  |  | 12-021F |  |  |  | 07-027 | 12-001 | XX |  |  |  |  | 11-049 |  |  |  |  |  |  |  |  |  |  |  |  |  |  |  |  |
| 1543080a |  | Preparing procument of GTP boards FY12 | 430d | 2011-05-23 A | 2013-02-11 A | 1543080 FS-130d | 100% |  | 2011-05-23 | 2013-02-15 |  |  |  | ELEC ENG [90.43 h] | 6,381.62 | 6,379.72 |  |  | 0 | 6380.7408 | CHUDAKOV | 1 | 1 | D | 07-024 | H | EUGENE C | 11-006 | 11-026 |  |  |  | 12-021F |  |  |  | 07-027 | 12-001 | XX |  |  |  |  | 11-049 |  |  |  |  |  |  |  |  |  |  |  |  |  |  |  |  |
| 1543016 |  | Programing FADC250 FPGAs FY11 | 274.46d | 2011-06-01 A | 2012-07-09 A | 9-110M | 100% |  |  |  |  |  |  | ELEC ENG [330.32 h] | 23,081.74 | 23,081.75 |  |  | 0 | 22587.2816 | CHUDAKOV | 1 | 1 | D |  | H | EUGENE C | 11-006 | 11-026 |  | DUP | 09-012 |  |  |  |  |  | 12-001 |  |  |  |  |  | 11-049 |  |  |  |  |  |  |  |  |  |  |  |  |  |  |  |  |
| 1543016a |  | Programing FADC250 FPGAs FY12 | 275d | 2011-06-01 A | 2012-07-09 A | 1543016 FS-120d | 100% |  |  |  |  |  |  | ELEC ENG [309.68 h] | 21,639.9 | 21,639.9 |  |  | 0 | 21851.0208 | CHUDAKOV | 1 | 1 | D |  | H | EUGENE C | 11-006 | 11-026 |  | DUP | 09-012 |  |  |  |  |  | 12-001 |  |  |  |  |  | 11-049 |  |  |  |  |  |  |  |  |  |  |  |  |  |  |  |  |
| 1543135 |  | Develop FADC250 features extraction algorithms (readout) (Hall D grp) | 387d | 2011-06-01 A | 2013-06-17 A | 9-120M FS-75d | 100% |  | 2011-06-01 | 2012-12-17 |  |  |  | SCIENTIST [320 h] | 22,540.64 | 22,725.13 |  |  | 0 | 22595.2 | CHUDAKOV | 1 | 1 | D | 07-024 | H | EUGENE C | 11-006 | 11-026 |  |  |  | 12-021F |  |  |  | 07-027 |  | XX |  |  |  |  |  |  |  |  |  |  |  |  |  |  |  |  |  |  |  |  |  |
| 1543110a |  | Testing of multi-crate board performance FY12 | 75d | 2011-07-01 A | 2011-10-17 A | 1543110 FS-70d | 100% |  |  |  |  |  |  | ELEC ENG [169.13 h]; SCIENTIST [45.1 h] | 14,719.8 | 14,719.8 |  |  | 0 | 15118.3238 | CHUDAKOV | 1 | 1 | D |  | U | EUGENE C | 11-006 | 11-026 |  |  |  | 12-021F |  |  |  |  | 12-001 |  |  |  |  |  |  |  |  |  |  |  |  |  |  |  |  |  |  |  |  |  |  |
| 1543105 |  | Full crate performance testing | 75d | 2011-07-09 A | 2011-10-24 A | 9-110M | 100% |  | 2011-07-11 | 2011-10-24 |  |  |  | ELEC ENG [126 h] | 8,674.48 | 8,674.48 |  |  | 0 | 8615.88 | CHUDAKOV | 1 | 1 | D |  | H | EUGENE C | 11-006 | 11-026 |  |  |  | 12-021F |  |  |  |  |  |  |  |  |  |  |  |  |  |  |  |  |  |  |  |  |  |  |  |  |  |  |  |
| 1543110 |  | Testing of multi-crate board performance FY11 | 69.26d | 2011-07-11 A | 2011-10-17 A | 9-110M | 100% |  |  |  |  |  |  | ELEC ENG [430.87 h]; SCIENTIST [114.9 h] | 37,501.78 | 37,501.78 |  |  | 0 | 37325.4976 | CHUDAKOV | 1 | 1 | D |  | U | EUGENE C | 11-006 | 11-026 |  |  |  | 12-021F |  |  |  |  | 12-001 |  |  |  |  |  |  |  |  |  |  |  |  |  |  |  |  |  |  |  |  |  |  |
| 1543130 |  | Implement playback mode | 97.16d | 2011-08-01 A | 2011-12-19 A | 9-120M FS-21d | 100% |  |  |  |  |  |  | SCIENTIST [120 h]; ELEC ENG [240 h] | 25,052.18 | 25,052.18 |  |  | 0 | 25407.6 | CHUDAKOV | 1 | 1 | D | 07-024 | H | EUGENE C | 11-006 | 11-026 |  |  |  | 12-021F |  |  |  | 07-027 |  |  |  |  |  |  |  |  |  |  |  |  |  |  |  |  |  |  |  |  |  |  |  |
| 1543012E |  | FY12 Travel (TRIGR) | 247d | 2011-10-03 A | 2012-09-28 A | 1543011E | 100% |  |  |  |  |  |  | TRAVEL | 1,223.82 |  | 100 | 100 | 0 | 1223.82 | CHUDAKOV | 1 | 1 | D | 07-024 | E | EUGENE C | 11-006 | 11-026 | 12-053 |  |  |  | 8.06451612 | 91.93548387 |  |  |  |  |  |  |  |  |  |  |  |  |  |  |  |  |  |  |  |  |  |  |  |  |  |
| 1543095 |  | Preparing procument of Fiber Optics Cable/Patch Pannel | 275d | 2011-11-07 A | 2013-08-30 A | 9-120M | 100% |  | 2011-11-07 | 2012-12-14 |  |  |  | ELEC ENG [120 h] | 8,519.24 | 8,604 |  |  | 4233.6 | 8467.2 | CHUDAKOV | 1 | 1 | D | 07-024 | H | EUGENE C | 11-006 | 11-026 |  |  |  | 12-021F |  |  |  | 07-027 |  | XX |  |  |  |  |  |  |  |  |  |  |  |  |  |  |  |  |  |  |  |  |  |
| 1543017 |  | Preparing procument of TS board | 44d | 2011-12-05 A | 2012-02-13 A | 9-120M | 100% |  |  |  |  |  |  | ELEC ENG [160 h] | 11,289.6 | 11,289.6 |  |  | 0 | 11289.6 | CHUDAKOV | 1 | 1 | D | 07-024 | H | EUGENE C | 11-006 | 11-026 |  | DUP | 09-012 | 12-021F |  |  |  |  |  |  |  |  |  |  |  |  |  |  |  |  |  |  |  |  |  |  |  |  |  |  |  |
| 1543085 |  | Procument of GTP boards (FE grp) Part A | 216d | 2012-01-09 A | 2012-11-12 A | 1543080a FS-125d, 9-120M | 100% |  |  |  |  |  |  | PROCUREMENT<$50K 60 NO ESCALATION FY13 | 3,319 |  |  |  | 0 | 3319 | CHUDAKOV | 1 | 1 | D | 07-024 | D | EUGENE C | 11-006 | 11-026 |  |  |  | 12-021 |  |  |  |  |  |  | 0 | 3319 | 331900 | 100 | 11-049 | 12-055 |  |  |  |  |  |  |  |  |  |  |  |  |  |  |  |
| 1543040 |  | Procument of TI-D boards (FE grp) Part A | 211d | 2012-01-16 A | 2012-11-12 A | 1543035 FS-70d, 9-120M | 100% |  | 2012-01-17 | 2012-11-12 |  |  |  | PROCUREMENT>$50K 69 NO ESCALATION FY13; PROCUREMENT<$50K 60 NO ESCALATION FY13 | 137,837.7 |  |  |  | 0 | 137837.7 | CHUDAKOV | 1 | 1 | D | 07-024 | D | EUGENE C | 11-006 | 11-026 |  |  |  | 12-021 |  |  |  | 07-027 |  |  | 0 | 137837.7 | 13783770 | 100 | 11-049 | 12-055 |  |  |  |  |  |  |  |  |  |  |  |  |  |  |  |
| 1543055 |  | Procument of SD boards (FE grp) Part A | 171d | 2012-01-16 A | 2012-09-17 A | 9-120M FS+21d, 1543050 | 100% |  | 2012-01-17 | 2012-09-17 |  |  |  | PROCUREMENT<$50K 60 NO ESCALATION FY13; PROCUREMENT>$50K 69 NO ESCALATION FY13 | 111,147 |  |  |  | 0 | 111147 | CHUDAKOV | 1 | 1 | D |  | D | EUGENE C | 11-006 | 11-026 |  | DUP | 09-012 | 12-021 |  |  | 08-052 |  |  |  | 0 | 111147 | 11114700 | 100 | 11-049 | 12-055 |  |  |  |  |  |  |  |  |  |  |  |  |  |  |  |
| 1543020 |  | Procument of TS board (FE grp) | 11d | 2012-02-03 A | 2012-02-20 A | 9-130M FS+43d, 1543017, 1543015 | 100% |  | 2012-02-03 | 2012-02-17 |  |  |  | PROCUREMENT<$50K 60 | 10,648.18 |  |  |  | 0 | 10648.18 | CHUDAKOV | 1 | 1 | D | 07-024 | D | EUGENE C | 11-006 | 11-026 |  | DUP | 09-012 | 12-021 |  |  |  |  |  |  | 0 | 10648.18 | 1064818 | 100 |  |  |  |  |  |  |  |  |  |  |  |  |  |  |  |  |  |
| 1543060 |  | Acceptance test of SD boards (FE grp) FY12 | 98.23d | 2012-06-02 A | 2012-10-22 A | 1543055 FS-99d, 1543055a FS-99d | 100% |  | 2012-06-05 | 2012-10-22 |  |  |  | ELEC ENG [164.32 h] | 11,651.74 | 11,651.74 |  |  | 0 | 11594.4192 | CHUDAKOV | 1 | 1 | D |  | H | EUGENE C | 11-006 | 11-026 | 12-053 | DUP | 09-012 | 12-021 |  |  |  |  |  |  |  |  |  |  | 11-049 |  |  |  |  |  |  |  |  |  |  |  |  |  |  |  |  |
| 1543060a |  | Acceptance test of SD boards (FE grp) FY13 | 99d | 2012-06-02 A | 2012-10-22 A | 1543060 FS-100d | 100% |  | 2012-06-05 | 2012-10-22 |  |  |  | ELEC ENG [155.68 h] | 11,041.39 | 11,041.39 |  |  | 0 | 11335.0608 | CHUDAKOV | 1 | 1 | D |  | H | EUGENE C | 11-006 | 11-026 | 12-053 | DUP | 09-012 | 12-021 |  |  |  |  |  |  |  |  |  |  | 11-049 |  |  |  |  |  |  |  |  |  |  |  |  |  |  |  |  |
| 1543065 |  | Preparing procument of SSP boards FY11 | 5d | 2012-06-02 A | 2012-06-11 A | 9-120M FS+160d | 100% |  | 2012-06-05 | 2012-06-11 |  |  |  | ELEC ENG [150.91 h] | 10,648.21 | 10,648.21 |  |  | 0 | 10319.2258 | CHUDAKOV | 1 | 1 | D |  | H | EUGENE C | 11-006 | 11-026 |  | DUP | 09-012 | 12-021F |  |  | 08-052 |  | 12-001 |  |  |  |  |  | 11-049 |  |  |  |  |  |  |  |  |  |  |  |  |  |  |  |  |
| 1543065a |  | Preparing procument of SSP boards FY12 | 11d | 2012-06-11 A | 2012-06-25 A | 1543065 | 100% |  |  |  |  |  |  | ELEC ENG [9.09 h] | 641.39 | 641.39 |  |  | 0 | 641.3904 | CHUDAKOV | 1 | 1 | D |  | H | EUGENE C | 11-006 | 11-026 |  | DUP | 09-012 | 12-021F |  |  | 08-052 |  | 12-001 |  |  |  |  |  | 11-049 |  |  |  |  |  |  |  |  |  |  |  |  |  |  |  |  |
| 1543023 |  | Preparing procument of CTP boards | 20d | 2012-06-12 A | 2012-07-09 A | 9-120M | 100% |  |  |  |  |  |  | ELEC ENG [160 h] | 11,289.6 | 11,289.6 |  |  | 0 | 10940.8 | CHUDAKOV | 1 | 1 | D | 07-024 | H | EUGENE C | 11-006 | 11-026 |  |  |  | 12-021F |  |  |  | 07-027 |  |  |  |  |  |  | 11-049 |  | IPL | 10-024 |  |  |  |  |  |  |  |  |  |  |  |  |  |
| 1543070 |  | Procument of SSP boards (FE grp) | 127d | 2012-06-18 A | 2013-02-11 A | 1543065a | 100% |  | 2012-06-18 | 2012-12-14 |  |  |  | PROCUREMENT<$50K 60; PROCUREMENT>$50K 69 | 53,240.88 |  |  |  | 0 | 53240.88 | CHUDAKOV | 1 | 1 | D |  | D | EUGENE C | 11-006 | 11-026 |  |  |  | 12-021 |  |  |  | 07-027 |  | XX | 0 | 53240.88 | 5324088 | 100 | 11-049 |  |  |  |  |  |  |  |  |  |  |  |  |  |  |  |  |
| 1543141 |  | Procure Equipment for Algorithm Test Stand ( Hall D grp ) Part A | 73d | 2012-08-01 A | 2012-11-12 A | 9-120M FS+141d | 100% |  |  |  |  |  |  | PROCUREMENT<$50K 60 | 8,100 |  |  |  | 0 | 8100 | CHUDAKOV | 1 | 1 | D |  | D | EUGENE C |  |  |  |  |  | 12-021 |  |  |  |  |  |  | 0 | 8100 | 810000 | 100 |  | 12-055 |  |  |  |  |  |  |  |  |  |  |  |  |  |  |  |
| 1543045 |  | Acceptance test of TI boards (FE grp) FY12 | 95d | 2012-09-10 A | 2012-12-17 A | 1543040 FS-99d, 1543040a FS-99d | 100% |  | 2012-09-10 | 2013-01-31 |  |  |  | ELEC ENG [164.32 h] | 11,905.76 | 11,883.77 |  |  | 0 | 11594.4192 | CHUDAKOV | 1 | 1 | D | 07-024 | U | EUGENE C | 11-006 | 11-026 | 12-053 |  |  | 12-021 |  |  |  | 07-027 |  |  |  |  |  |  | 11-049 |  |  |  |  |  |  |  |  |  |  |  |  |  |  |  |  |
| 1543013E |  | FY13 Travel (TRIGR) | 58d | 2012-10-01 A | 2012-12-31 A | 1543012E | 100% |  | 2012-10-01 | 2012-12-21 |  |  |  | TRAVEL | 316.32 |  | 100 | 100 | 0 | 316.32 | CHUDAKOV | 1 | 1 | D | 07-024 | E | EUGENE C | 11-006 | 11-026 | 12-053 |  |  |  | 25.86206896 | 74.13793103 |  |  |  |  |  |  |  |  |  |  |  |  |  |  |  |  |  |  |  |  |  |  |  |  |  |
| 1543040a |  | Procument of TI-D boards (FE grp) Part B | 31d | 2012-10-01 A | 2012-11-12 A | 9-120M, 1543035 FS-70d | 100% |  |  |  |  |  |  | PROCUREMENT>$50K 69 | 51,000 |  |  |  | 0 | 51000 | CHUDAKOV | 1 | 1 | D | 07-024 | D | EUGENE C | 11-006 | 11-026 |  |  |  | 12-021 |  |  |  | 07-027 |  |  | 0 | 51000 | 5100000 | 100 | 11-049 | 12-055 |  |  |  |  |  |  |  |  |  |  |  |  |  |  |  |
| 1543055a |  | Procument of SD boards (FE grp) Part B | 16d | 2012-10-01 A | 2012-10-22 A | 1543050, 9-120M FS+21d | 100% |  |  |  |  |  |  | PROCUREMENT>$50K 69 NO ESCALATION FY13 | 23,000 |  |  |  | 0 | 23000 | CHUDAKOV | 1 | 1 | D |  | D | EUGENE C | 11-006 | 11-026 |  | DUP | 09-012 | 12-021 |  |  | 08-052 |  |  |  | 0 | 23000 | 2300000 | 100 | 11-049 | 12-055 |  |  |  |  |  |  |  |  |  |  |  |  |  |  |  |
| 1543025 |  | Procument of CTP boards (FE grp) | 41d | 2012-12-03 A | 2013-08-30 A | 9-130M, 1543023 | 100% |  | 2013-01-02 | 2013-03-01 |  |  |  | PROCUREMENT>$50K 69; PROCUREMENT<$50K 60 | 133,102.2 |  |  |  | 119791.98 | 133102.2 | CHUDAKOV | 1 | 1 | D | 07-024 | D | EUGENE C | 11-006 | 11-026 |  |  |  | 12-021 |  |  |  | 07-027 |  | XX | 0 | 133102.2 | 13310220 | 100 | 11-049 |  | IPL | 10-024 |  |  |  |  |  |  |  |  |  |  |  |  |  |
| 1543100 |  | Procument Fiber Optics Cable/Patch Pannel (FE grp) | 140d | 2012-12-03 A | 2013-08-30 A | 1543095 FS-70d | 100% |  | 2013-01-16 | 2013-08-05 |  |  |  | PROCUREMENT<$50K 60 | 20,638 |  |  |  | 4127.6 | 20638 | CHUDAKOV | 1 | 1 | D |  | D | EUGENE C | 11-006 | 11-026 |  |  |  | 12-021 |  |  |  | 07-027 |  |  | 0 | 20638 | 2063800 | 100 |  |  | IPL |  |  |  |  |  |  |  |  |  |  |  |  |  |  |
| 1543141a |  | Procure Equipment for Algorithm Test Stand ( Hall D grp ) Part B | 45d | 2013-02-01 A | 2013-02-11 A | 9-120M FS+141d | 100% |  | 2013-03-01 | 2013-05-02 |  |  |  | PROCUREMENT<$50K 60 | 10,000 |  |  |  | 0 | 10000 | CHUDAKOV | 1 | 1 | D |  | D | EUGENE C |  |  |  |  |  | 12-021 |  |  |  |  |  |  | 0 | 10000 | 1000000 | 100 |  | 12-055 |  |  |  |  |  |  |  |  |  |  |  |  |  |  |  |
| 1543115 |  | Performance testing of global trigger system | 150d | 2013-03-04 A | 2013-08-30 A | 9-120M FS+65d, 1543060a, 1543110a, 182443005, 1543105, 182443015 FS-120d, 1543100 FS-70d, 182443010 FS-120d, 182443000 FS-150d | 100% |  | 2013-08-19 | 2014-03-31 |  |  |  | ELEC ENG [640 h]; SCIENTIST [320 h] | 71,695.36 | 69,913.6 |  |  | 46842.112 | 30295.893334 | CHUDAKOV | 1 | 1 | D |  | S | EUGENE C | 11-006 | 11-026 |  |  |  | 12-021 |  |  |  |  |  |  |  |  |  |  | 11-049 |  |  |  | ST |  |  |  |  |  |  |  |  |  |  |  |  |
| 1543085a |  | Procument of GTP boards (FE grp) Part B | 64d | 2013-05-03 A | 2013-06-17 A | 1543080a FS-30d, 9-130M FS+120d, 9-120M | 100% |  | 2013-06-03 | 2013-08-30 |  |  |  | PROCUREMENT<$50K 60 NO ESCALATION FY13 | 7,000 |  |  |  | 0 | 7000 | CHUDAKOV | 1 | 1 | D | 07-024 | D | EUGENE C | 11-006 | 11-026 |  |  |  | 12-021 |  |  |  |  |  |  | 0 | 7000 | 700000 | 100 | 11-049 | 12-055 |  |  |  |  |  |  |  |  |  |  |  |  |  |  |  |
| 1543142 |  | Prepair Test Stand for Algorithm Testing, Test Algorithms ( Hall D grp ) | 267d | 2013-05-03 A | 2013-08-26 A | 1543141, 9-120M FS+228d, 1543141a | 100% |  | 2013-06-03 | 2014-06-27 |  |  |  | SCIENTIST [683.15 h] | 50,860.59 | 49,774.31 |  |  | 40801.6 | 49774.309 | CHUDAKOV | 1 | 1 | D |  | S | EUGENE C |  |  | 12-053 |  |  | 12-021 |  |  |  |  |  |  |  |  |  |  |  |  |  |  | ST | 12-054 |  |  |  |  |  |  |  |  |  |  |  |
| 1543150 |  | Re-Baseline Actuals Adjustment | 1d | 2013-08-30 A | 2013-08-30 A |  | 100% |  | 2013-09-03 | 2013-09-03 |  |  |  | PROCUREMENT>$50K 69 NO ESCALATION | 227,586.42 |  |  |  |  | 227586.42 |  |  |  |  |  |  |  |  |  |  |  |  |  |  |  |  |  |  |  | 0 | 227586.42 | 22758642 | 100 |  |  |  |  |  |  | ADJ |  |  |  |  |  |  |  |  |  |  |
| 2543025 |  | Procument of CTP boards (FE grp) (Previously Obligated) | 20d | 2013-09-03 A | 2014-01-21 | 9-130M FS+228d |  | 47d | 2013-10-01 | 2013-10-28 | 78d | 0d | 8/5 M-F w/JLAB Holidays ReBaseline | PROCUREMENT<$50K 60; PROCUREMENT>$50K 69 | 18,009.16 |  |  |  |  | -18009.16 | CHUDAKOV | 1 | 1 | D | 07-024 | D | EUGENE C | 11-006 | 11-026 |  |  |  | 12-021 |  |  |  | 07-027 |  |  | 18009.16 | 0 | 0 | 100 | 11-049 |  | IPL | 10-024 |  |  |  | 2543025 | 18009.16 | 12-047F | OB | 13-015 | PR | OB |  |  |  |
| 2543030 |  | Procument of CTP boards (FE grp) | 20d | 2013-09-03 A | 2013-09-23 A | 9-130M FS+228d | 100% |  | 2013-10-01 | 2013-10-28 |  |  | 8/5 M-F w/JLAB Holidays ReBaseline | PROCUREMENT<$50K 60; PROCUREMENT>$50K 69 | 9,682 |  |  |  |  | 0 | CHUDAKOV | 1 | 1 | D | 07-024 | D | EUGENE C | 11-006 | 11-026 |  |  |  | 12-021 |  |  |  | 07-027 |  |  | 0 | 9682 | 968200 | 100 | 11-049 |  | IPL | 10-024 |  |  |  | 2543025 | 9682 | 12-047F | OB | 13-015 | PR | OB-2 |  |  |  |
| 2543160 |  | Trigger Board Initialization (Hall D grp) FY13 | 20d | 2013-09-03 A | 2014-09-19 | 9-130M FS+228d |  | 217d | 2013-10-01 | 2013-10-28 | 7d |  | 8/5 M-F w/JLAB Holidays ReBaseline | SCIENTIST [46.77 h] | 3,516.17 | 573.17 |  |  |  | 0 | CHUDAKOV | 1 | 1 | D |  | S | EUGENE C |  |  |  |  |  | 12-021 |  |  |  |  |  |  |  |  |  |  |  |  |  |  | ST | 12-054 |  | 2543160 |  |  |  | 13-015 | PR |  | EJ |  |  |
| 2543160a |  | Trigger Board Initialization (Hall D grp) FY14 | 240d | 2013-09-03 A | 2014-09-19 | 2543160 FS-260d |  | 217d | 2013-10-01 | 2014-09-19 | 7d |  | 8/5 M-F w/JLAB Holidays ReBaseline | SCIENTIST [561.23 h] | 42,193.27 | 6,877.96 |  |  |  | 0 | CHUDAKOV | 1 | 1 | D |  | S | EUGENE C |  |  |  |  |  | 12-021 |  |  |  |  |  |  |  |  |  |  |  |  |  |  | ST | 12-054 |  | 2543160 |  |  |  | 13-015 | PR |  | EJ | 14-001 |  |
| 2543185 |  | Procument Structural Components for Trigger Modules (FE Grp) | 17d | 2013-09-03 A | 2013-11-25 | 9-130M FS+228d |  | 17d | 2013-10-01 | 2013-10-23 | 207d |  | 8/5 M-F w/JLAB Holidays ReBaseline | PROCUREMENT<$50K 60 | 1,448.62 |  |  |  |  | 0 | CHUDAKOV | 1 | 1 | D |  | D | EUGENE C |  |  |  |  |  | 12-021 |  |  |  |  |  |  | 1448.62 | 0 | 0 | 100 |  |  |  |  |  | 12-054 |  | 2543185 |  |  |  | 13-015 | PR | OB |  |  | PE |
| 2543150 |  | Develop Level-1 Monitor (Hall D grp) FY13 | 20d | 2013-10-01 A | 2014-05-30 | 9-130M FS+228d, 9-140M FS+15d | 10% | 139d | 2013-11-01 | 2013-12-02 | 286d | 0d | 8/5 M-F w/JLAB Holidays ReBaseline | SCIENTIST [39.56 h]; ELEC ENG [8.79 h] | 3,634.51 | 516.01 |  |  |  | 352.2341454 | CHUDAKOV | 1 | 1 | D |  | S | EUGENE C |  |  |  |  |  | 12-021 |  |  |  |  |  |  |  |  |  |  |  |  |  |  | ST | 12-054 |  | 2543150 |  |  |  | 13-015 | PR |  | PE |  |  |
| 2543150a |  | Develop Level-1 Monitor (Hall D grp) FY14 | 162d | 2013-10-01 A | 2014-05-30 | 2543150 FS-150d | 10% | 139d | 2013-12-03 | 2014-07-31 | 286d | 0d | 8/5 M-F w/JLAB Holidays ReBaseline | SCIENTIST [320.44 h]; ELEC ENG [71.21 h] | 29,440.69 | 4,179.85 |  |  |  | 2944.0686546 | CHUDAKOV | 1 | 1 | D |  | S | EUGENE C |  |  |  |  |  | 12-021 |  |  |  |  |  |  |  |  |  |  |  |  |  |  | ST | 12-054 |  | 2543150 |  |  |  | 13-015 | PR |  | PE | 14-001 |  |
| 2543100 |  | Procument Fiber Optics Cable/Patch Pannel (FE grp) | 34d | 2013-10-21 A | 2013-12-20 | 9-140M | 2% | 34d | 2013-12-02 | 2014-01-30 | 128d | 50d | 8/5 M-F w/JLAB Holidays ReBaseline | PROCUREMENT<$50K 60 | 36,116.5 |  |  |  |  | 722.33 | CHUDAKOV | 1 | 1 | D |  | D | EUGENE C | 11-006 | 11-026 |  |  |  | 12-021 |  |  |  | 07-027 |  |  | 35394.17 | 722.33 | 72233 | 100 |  |  | IPL |  |  |  |  | 2543100 |  |  | EV | 13-015 | PR | OB-2 |  | 14-001 |  |
| 2543165 |  | Level-1 Verification and Debugging (Hall D grp) FY13 | 20d | 2013-11-15 | 2013-12-16 | 9-140M FS+33d, 9-130M FS+228d |  |  |  |  | 9d | 0d | 8/5 M-F w/JLAB Holidays ReBaseline | SCIENTIST [23.42 h]; ELEC ENG [3.9 h] | 2,053.72 |  |  |  |  | 0 | CHUDAKOV | 1 | 1 | D |  | S | EUGENE C |  |  |  |  |  | 12-021 |  |  |  |  |  |  |  |  |  |  |  |  |  |  | ST | 12-054 |  | 2543165 |  |  |  | 13-015 | PR |  | PE |  |  |
| 2543170 |  | Level-1 Trigger Testbed Electronics (Hall D grp) | 49d | 2013-12-05 | 2014-02-24 | 9-140M FS+45d |  |  |  |  | 1d | 0d | 8/5 M-F w/JLAB Holidays ReBaseline | PROCUREMENT<$50K 60 | 19,864.08 |  |  |  |  | 0 | CHUDAKOV | 1 | 1 | D |  | D | EUGENE C |  |  |  |  |  | 12-021 |  |  |  |  |  |  | 19864.08 | 0 | 0 | 100 |  |  |  |  |  | 12-054 |  | 2543170 |  |  | VQ | 13-015 | PR |  |  | 14-001 |  |
| 2543115 |  | Performance testing of global trigger system (FE grp) | 44d | 2013-12-12 | 2014-02-24 | 2543100 FS-57d, 2543030 FS-20d, 2543025 FS-20d, 282443010a FS-100d, 282443010 FS-100d |  |  |  |  | 78d | 0d | 8/5 M-F w/JLAB Holidays ReBaseline | ELEC ENG [360 h]; SCIENTIST [26.8 h] | 29,061.62 |  |  |  |  | 0 | CHUDAKOV | 1 | 1 | D |  | S | EUGENE C | 11-006 | 11-026 |  |  |  | 12-021 |  |  |  |  |  |  |  |  |  |  | 11-049 |  |  |  | ST |  |  | 2543115 |  |  |  | 13-015 | PR |  | EJ | 14-001 |  |
| 2543144 |  | Study Algorithms with Test Stand (Hall D grp) FY13 | 20d | 2013-12-17 | 2014-01-24 | 9-140M FS+53d, 9-130M FS+228d |  |  |  |  | 64d | 0d | 8/5 M-F w/JLAB Holidays ReBaseline | SCIENTIST [15.76 h] | 1,184.84 |  |  |  |  | 0 | CHUDAKOV | 1 | 1 | D |  | S | EUGENE C |  |  |  |  |  | 12-021 |  |  |  |  |  |  |  |  |  |  |  |  |  |  | ST | 12-054 |  | 2543144 |  |  |  | 13-015 | PR |  | PE |  |  |
| 2543165a |  | Level-1 Verification and Debugging (Hall D grp) FY14 | 185d | 2013-12-17 | 2014-09-17 | 2543165 |  |  |  |  | 9d |  | 8/5 M-F w/JLAB Holidays ReBaseline | SCIENTIST [216.58 h]; ELEC ENG [36.1 h] | 18,994.68 |  |  |  |  | 0 | CHUDAKOV | 1 | 1 | D |  | S | EUGENE C |  |  |  |  |  | 12-021 |  |  |  |  |  |  |  |  |  |  |  |  |  |  | ST | 12-054 |  | 2543165 |  |  |  | 13-015 | PR |  | PE | 14-001 |  |
| 2543144a |  | Study Algorithms with Test Stand (Hall D grp) FY14 | 110d | 2014-01-27 | 2014-06-30 | 2543144 |  |  |  |  | 64d |  | 8/5 M-F w/JLAB Holidays ReBaseline | SCIENTIST [144.24 h] | 10,843.96 |  |  |  |  | 0 | CHUDAKOV | 1 | 1 | D |  | S | EUGENE C |  |  |  |  |  | 12-021 |  |  |  |  |  |  |  |  |  |  |  |  |  |  | ST | 12-054 |  | 2543144 |  |  |  | 13-015 | PR |  | PE | 14-001 |  |
| 2543143 |  | Trigger Algorithms Performance Testing in the Hall (Hall D grp) | 162d | 2014-02-11 | 2014-09-29 | 9-140M FS+62d, 2543170 FS-10d |  |  |  |  | 1d |  | 8/5 M-F w/JLAB Holidays ReBaseline | SCIENTIST [360 h] | 27,064.8 |  |  |  |  | 0 | CHUDAKOV | 1 | 1 | D |  | S | EUGENE C |  |  |  |  |  | 12-021 |  |  |  |  |  |  |  |  |  |  |  |  |  |  | ST | 12-054 |  | 2543143 |  |  |  | 13-015 | PR |  | PE | 14-001 |  |
| 2543155 |  | Install Level-1 Monitor (Hall D grp) | 85d | 2014-06-02 | 2014-09-30 | 2543150a, 2543150 |  |  |  |  | 286d | 62d | 8/5 M-F w/JLAB Holidays ReBaseline | SCIENTIST [200 h] | 15,036 |  |  |  |  | 0 | CHUDAKOV | 1 | 1 | D |  | S | EUGENE C |  |  |  |  |  | 12-021 |  |  |  |  |  |  |  |  |  |  |  |  |  |  | ST | 12-054 |  | 2543155 |  |  |  | 13-015 | PR |  | PE | 14-001 |  |

Notes:
- 1543023: Explanation: IPL from 6 GeV 5543500M
- 1543025: Explanation: IPL from 6 GeV 5543500M
- 1543100: Explanation: IPL from 6 GeV 5543500M
- 1543115: Steps: Overall trigger latency test, mesasurements and verification (done); Full trigger rate, serial link and synchronization verification measurements (done); Final firmware iterations, test and measurement results (done)
- 1543142: Steps: Assemble test setup (done); Prepare analysis software (done); Program electronics boards (done); Implement Playback mode (done)
- 2543025: Explanation: IPL from 6 GeV 5543500M
- 2543030: Explanation: IPL from 6 GeV 5543500M
- 2543160: Steps: implement Run Config files; implement Run Config DB; develop database GUI; check performance with test stand; final implementation; develop run configurations for sub-detectors
- 2543160a: Steps: implement Run Config files; implement Run Config DB; develop database GUI; check performance with test stand; final implementation; develop run configurations for sub-detectors
- 2543150: Steps: implement/check scalers for fadc250 (done); implement/check scalers for CTP/SSP; implement/check scalers for GTP; implement/check scalers for TS; develop GUI monitor for BCAL; develop GUI monitor for FCAL; develop GUI monitor for Tagger detectors; develop GUI monitor for PS; develop GUI monitor for TOF/SC; develop GUI monitor for global trigger and trigger distribution crates
- 2543150a: Steps: implement/check scalers for fadc250 (done); implement/check scalers for CTP/SSP; implement/check scalers for GTP; implement/check scalers for TS; develop GUI monitor for BCAL; develop GUI monitor for FCAL; develop GUI monitor for Tagger detectors; develop GUI monitor for PS; develop GUI monitor for TOF/SC; develop GUI monitor for global trigger and trigger distribution crates
- 2543100: Explanation: IPL from 6 GeV 5543500M
- 2543165: Steps: software development for the play back implementation; develop bitwise simulation; develop software for event analyzer; check performance with the trigger test stand
- 2543115: Steps: Full trigger rate; serial link and synchronization verification measurements; Final firmware iterations; test and measurement results
- 2543144: Steps: cosmic triggers; hit pattern triggers; PS trigger; physics triggers
- 2543165a: Steps: software development for the play back implementation; develop bitwise simulation; develop software for event analyzer; check performance with the trigger test stand
- 2543144a: Steps: cosmic triggers; hit pattern triggers; PS trigger; physics triggers
- 2543143: Steps: Assemble test setup; Prepair analysing software; Program electronics boards; Implement Play Back Mode; Algorithm Performance Studies
- 2543155: Steps: check monitor performance with the test stand; checked performance with installed detectors: BCAL; checked performance with installed detectors: FCAL; checked performance with installed detectors: Tagger Detectors; checked performance with installed detectors: PS; checked performance with installed detectors: TOF/SC; checked performance with installed detectors: Global Trigger Crate

| ID | WBS | Activity | Duration | Start | Finish | Predecessors | Complete | Planned start | Planned finish | Resources | Cost | Actual cost | Remaining Material Cost Based on % Compl | Claimed Material Cost Based on % Complet | Initial Claimed Material Calc | Claimed Material Divider | Calculated Remaining Total Cost | MONTHLY EV COST | RESP - Responsibility | STRT%COMP for CM EVM | FNSH%COMP for CM EVM | HALL D Related Milestones | Advance Purchase Plan > 500K | EVMS Reporting Codes | CAM RESPONSIBLE | CR 08-035 | 12 GEV MAJOR PROCUREMENT CATAGORY | CR 10-053 | CR 10-077 | CR 11-006 | CR 11-026 | CR 12-021 | Profile change | CR 12-054 | CR 12-001 | Phil Dev | CR 08-038 | CR 09-012 | MARCH!!! | New H Claim | ReBaseline Actuals Adjustment | LOE Divider | LOE Multiplier | CR 07-024 | CR 07-027 | CR 08-058 | CR 08-036 | CR 10-024 | CR 11-002 | CR 11-029 | LOE % Pre Calc | LOE % | Inter Project Link (IPL) | CR 09-014 | CR 10-042 | CR 12-016 | Duplications | CR 09-045 | CR 10-054 | CR 12-053 |
| --- | --- | --- | --- | --- | --- | --- | --- | --- | --- | --- | --- | --- | --- | --- | --- | --- | --- | --- | --- | --- | --- | --- | --- | --- | --- | --- | --- | --- | --- | --- | --- | --- | --- | --- | --- | --- | --- | --- | --- | --- | --- | --- | --- | --- | --- | --- | --- | --- | --- | --- | --- | --- | --- | --- | --- | --- | --- | --- | --- | --- |
|  | 4 | **1.5.4.4 CRATES/RACKS** |  | 2010-09-30 | 2013-08-30 |  |  |  |  |  |  |  |  |  |  |  |  |  |  |  |  |  |  |  |  |  |  |  |  |  |  |  |  |  |  |  |  |  |  |  |  |  |  |  |  |  |  |  |  |  |  |  |  |  |  |  |  |  |  |  |
| 1544005 |  | Vend Fab Crate DAQ Type Phase 1 (CRATES/RACKS) Peg Point #1 VXS Prototype | 74d | 2010-09-30 A | 2011-01-24 A | 1234180M, 9-110M FS-1d | 100% |  |  | PROCUREMENT>$50K 69 NO ESCALATION FY11; PROCUREMENT<$50K 60 NO ESCALATION FY11 | 15,116 |  | 0 | 15116 | 1511600 | 100 | 0 | 15116 | CHUDAKOV | 1 | 1 | D | APP | D | EUGENE C | 08-035 | 544B | 10-053 | 10-077 | 11-006 | 11-026 | 12-021F |  |  |  |  |  |  |  |  |  |  |  |  |  |  |  |  |  |  |  |  |  |  |  |  |  |  |  |  |
| 1544005a |  | Vend Fab Crate DAQ Type Phase 1 (CRATES/RACKS) Peg Point #2 VME64X Qty 1 | 93d | 2010-09-30 A | 2011-02-21 A | 1544005 FS-59d | 100% | 2010-09-30 | 2011-02-18 | PROCUREMENT<$50K 60 NO ESCALATION FY11; PROCUREMENT>$50K 69 NO ESCALATION FY11 | 7,232 |  | 0 | 7232 | 723200 | 100 | 0 | 7232 | CHUDAKOV | 1 | 1 | D | APP | D | EUGENE C | 08-035 | 544B | 10-053 | 10-077 | 11-006 | 11-026 | 12-021F |  |  |  |  |  |  |  |  |  |  |  |  |  |  |  |  |  |  |  |  |  |  |  |  |  |  |  |  |
| 1544005b |  | Vend Fab Crate DAQ Type Phase 1 (CRATES/RACKS) Peg Point #3 VME64X Qty 6 | 93d | 2010-09-30 A | 2011-02-21 A | 1544005a FS-98d | 100% | 2010-09-30 | 2011-02-18 | PROCUREMENT<$50K 60 NO ESCALATION FY11; PROCUREMENT>$50K 69 NO ESCALATION FY11 | 43,392 |  | 0 | 43392 | 4339200 | 100 | 0 | 43392 | CHUDAKOV | 1 | 1 | D | APP | D | EUGENE C | 08-035 | 544B | 10-053 | 10-077 | 11-006 | 11-026 | 12-021F |  |  |  |  |  |  |  |  |  |  |  |  |  |  |  |  |  |  |  |  |  |  |  |  |  |  |  |  |
| 1544005c |  | Vend Fab Crate DAQ Type Phase 1 (CRATES/RACKS) Peg Point #4 VXS Qty 3 | 147d | 2010-09-30 A | 2011-05-08 A | 1544005b FS-98d | 100% | 2010-09-30 | 2011-05-06 | PROCUREMENT<$50K 60 NO ESCALATION FY11; PROCUREMENT>$50K 69 NO ESCALATION FY11 | 32,604 |  | 0 | 32604 | 3260400 | 100 | 0 | 32604 | CHUDAKOV | 1 | 1 | D | APP | D | EUGENE C | 08-035 | 544B | 10-053 | 10-077 | 11-006 | 11-026 | 12-021F |  |  |  |  |  |  |  |  |  |  |  |  |  |  |  |  |  |  |  |  |  |  |  |  |  |  |  |  |
| 1544005d |  | Vend Fab Crate DAQ Type Phase 1 (CRATES/RACKS) Peg Point #5 VXS Qty 8 | 147d | 2010-09-30 A | 2011-05-08 A | 1544005c FS-121d | 100% | 2010-09-30 | 2011-05-06 | PROCUREMENT<$50K 60 NO ESCALATION FY11; PROCUREMENT>$50K 69 NO ESCALATION FY11 | 86,944 |  | 0 | 86944 | 8694400 | 100 | 0 | 86944 | CHUDAKOV | 1 | 1 | D | APP | D | EUGENE C | 08-035 | 544B | 10-053 | 10-077 | 11-006 | 11-026 | 12-021F |  |  |  |  |  |  |  |  |  |  |  |  |  |  |  |  |  |  |  |  |  |  |  |  |  |  |  |  |
| 1544050 |  | Racks - First Article Procurement Support (CRATES/RACKS) | 26d | 2011-04-18 A | 2011-05-23 A | 1234180M, 9-110M | 100% |  |  | ELEC ENG [40 h]; ELEC TECH [160 h] | 9,578.4 | 9,578.4 |  |  |  |  | 0 | 9578.4 | CHUDAKOV | 1 | 1 | D | APP | H | EUGENE C |  | 544A |  |  | 11-006 | 11-026 | 12-021F | C | 12-054F |  |  |  |  |  |  |  |  |  |  |  |  |  |  |  |  |  |  |  |  |  |  |  |  |  |  |
| 1544055 |  | Racks - First Article Parts (QTY 2) (CRATES/RACKS) | 26d | 2011-04-18 A | 2011-05-23 A | 1544050 FS-25d | 100% |  |  | PROCUREMENT<$50K 60 | 2,400 |  | 0 | 2400 | 240000 | 100 | 0 | 2400 | CHUDAKOV | 1 | 1 | D | APP | H | EUGENE C |  | 544A |  |  | 11-006 | 11-026 | 12-021F | C | 12-054F |  |  |  |  |  |  |  |  |  |  |  |  |  |  |  |  |  |  |  |  |  |  |  |  |  |  |
| 1544060 |  | Racks - Cabling Development (CRATES/RACKS) FY11 | 172.51d | 2011-06-01 A | 2012-02-13 A | 1544055 FS+5d | 100% |  |  | ELEC ENG [49.87 h]; ELEC TECH [74.81 h] | 6,715.28 | 6,715.28 |  |  |  |  | 0 | 6609.7343 | CHUDAKOV | 1 | 1 | D | APP | H | EUGENE C |  | 544A |  |  | 11-006 | 11-026 | 12-021F | C | 12-054F | 12-001 |  |  |  |  |  |  |  |  |  |  |  |  |  |  |  |  |  |  |  |  |  |  |  |  |  |
| 1544060a |  | Racks - Cabling Development (CRATES/RACKS) FY12 | 173d | 2011-06-01 A | 2012-02-13 A | 1544060 FS-55d | 100% |  |  | ELEC TECH [165.19 h]; ELEC ENG [110.13 h] | 14,829.57 | 14,829.57 |  |  |  |  | 0 | 15060.6075 | CHUDAKOV | 1 | 1 | D | APP | H | EUGENE C |  | 544A |  |  | 11-006 | 11-026 | 12-021F | C | 12-054F | 12-001 |  |  |  |  |  |  |  |  |  |  |  |  |  |  |  |  |  |  |  |  |  |  |  |  |  |
| 1544006 |  | Vend Fab Crate DAQ Type Phase 2 (CRATES/RACKS) VXS | 279d | 2011-11-01 A | 2012-12-17 A | 1544005d, 9-120M | 100% | 2011-11-01 | 2012-12-14 | PROCUREMENT<$50K 60 NO ESCALATION; PROCUREMENT>$50K 69 NO ESCALATION | 386,391 |  | 0 | 386391 | 38639100 | 100 | 0 | 386391 | CHUDAKOV | 1 | 1 | D | APP | D | EUGENE C |  | 544B | 10-053 | 10-077 | 11-006 | 11-026 |  |  |  |  | MP |  |  |  |  |  |  |  |  |  |  |  |  |  |  |  |  |  |  |  |  |  |  |  |  |
| 1544010 |  | Vend Fab Crate DAQ Type Phase 2 (CRATES/RACKS) VME64X | 90d | 2011-11-01 A | 2012-03-19 A | 1234180M, 1544005d, 9-120M | 100% |  |  | PROCUREMENT>$50K 69 NO ESCALATION | 13,914 |  | 0 | 13914 | 1391400 | 100 | 0 | 13914 | CHUDAKOV | 1 | 1 | D | APP | D | EUGENE C |  | 544A |  | 10-077 | 11-006 | 11-026 |  |  |  |  |  | 08-038 |  |  |  |  |  |  |  |  |  |  |  |  |  |  |  |  |  |  |  |  |  |  |  |
| 1544030 |  | Proc TDC Auxiliaries (CRATES/RACKS) | 1d | 2011-12-03 A | 2011-12-05 A | 1544005d, 9-120M FS+42d, 1234180M | 100% | 2011-12-05 | 2011-12-05 |  |  |  |  |  |  |  |  | 0 | CHUDAKOV | 1 | 1 | D | APP | Z | EUGENE C |  | 544A |  |  | 11-006 | 11-026 |  | C |  |  |  | 08-038 | 09-012 |  |  |  |  |  |  |  |  |  |  |  |  |  |  |  |  |  |  |  |  |  |  |
| 1544065 |  | Racks - Production Procurement Support (CRATES/RACKS) | 102d | 2012-01-16 A | 2012-06-11 A | 1544060a FS-30d | 100% | 2012-01-17 | 2012-06-11 | ELEC TECH [160 h]; ELEC ENG [40 h] | 9,883.2 | 9,883.2 |  |  |  |  | 0 | 9883.2 | CHUDAKOV | 1 | 1 | D | APP | H | EUGENE C |  | 544A |  |  | 11-006 | 11-026 | 12-021F | C | 12-054F |  |  |  |  |  |  |  |  |  |  |  |  |  |  |  |  |  |  |  |  |  |  |  |  |  |  |
| 1544070 |  | Racks - Production Parts (QTY 55) (CRATES/RACKS) | 134d | 2012-02-03 A | 2012-08-13 A | 9-120M, 1544065 FS-30d | 100% |  |  | PROCUREMENT<$50K 60; PROCUREMENT>$50K 69 | 68,105.4 |  | 0 | 68105.4 | 6810540 | 100 | 0 | 68105.4 | CHUDAKOV | 1 | 1 | D | APP | D | EUGENE C |  | 544A |  |  | 11-006 | 11-026 | 12-021 | C | 12-054F |  |  |  |  |  |  |  |  |  |  |  |  |  |  |  |  |  |  |  |  |  |  |  |  |  |  |
| 1544075 |  | Racks - Production Acceptance (CRATES/RACKS) | 104d | 2012-03-19 A | 2012-08-13 A | 1544070 FS-70d | 100% |  |  | ELEC TECH [160 h] | 7,060.8 | 7,060.8 |  |  |  |  | 0 | 7060.8 | CHUDAKOV | 1 | 1 | D | APP | U | EUGENE C |  | 544A |  |  | 11-006 | 11-026 | 12-021 | C | 12-054F |  |  |  |  |  |  |  |  |  |  |  |  |  |  |  |  |  |  |  |  |  |  |  |  |  |  |
| 1544015 |  | Vend Fab Crate supl (5 VXS and 2 VME64) | 186d | 2012-04-02 A | 2012-12-17 A | 9-120M FS+138d | 100% | 2012-04-02 | 2012-12-31 | PROCUREMENT<$50K 60 NO ESCALATION FY13; PROCUREMENT>$50K 69 NO ESCALATION FY13 | 70,000 |  | 0 | 70000 | 7000000 | 100 | 0 | 70000 | CHUDAKOV | 1 | 1 | D | APP | D | EUGENE C |  | 544A |  | 10-077 | 11-006 | 11-026 | 12-021 |  |  |  | MP | 08-038 |  |  |  |  |  |  |  |  |  |  |  |  |  |  |  |  |  |  |  |  |  |  |  |
| 1544035 |  | Assemble TDC Crates (CRATES/RACKS) | 95d | 2012-08-01 A | 2013-01-31 A | 1544030, 1544006 FS-125d, 1544010 | 100% | 2012-08-01 | 2012-12-14 | ELEC TECH [80 h] | 3,593.33 | 3,604.37 |  |  |  |  | 0 | 3530.4 | CHUDAKOV | 1 | 1 | D |  | U | EUGENE C |  |  |  |  | 11-006 | 11-026 |  |  |  |  |  |  |  | XX |  |  |  |  |  |  |  |  |  |  |  |  |  |  |  |  |  |  |  |  |  |
| 1544025 |  | Test ADC Crates (CRATES/RACKS) | 125d | 2012-08-06 A | 2013-01-31 A | 1544020 FS-40d | 100% | 2012-08-06 | 2013-02-08 | ELEC TECH [360 h] | 16,236.03 | 16,228.04 |  |  |  |  | 0 | 15886.8 | CHUDAKOV | 1 | 1 | D |  | U | EUGENE C |  |  |  | 10-077 | 11-006 | 11-026 |  |  |  |  |  |  |  | XX | Aug 12 |  |  |  |  |  |  |  |  |  |  |  |  |  |  |  |  |  |  |  |  |
| 1544040 |  | Test TDC Crates (CRATES/RACKS) | 125d | 2012-08-06 A | 2013-01-31 A | 1544035 FS-60d | 100% | 2012-08-06 | 2013-02-08 | ELEC TECH [160 h] | 7,216.01 | 7,212.46 |  |  |  |  | 0 | 7060.8 | CHUDAKOV | 1 | 1 | D |  | U | EUGENE C |  |  |  |  | 11-006 | 11-026 |  |  |  |  |  |  |  | XX | Aug 12 |  |  |  |  |  |  |  |  |  |  |  |  |  |  |  |  |  |  |  |  |
| 1544020 |  | Assemble ADC Crates (CRATES/RACKS) | 87d | 2012-08-13 A | 2013-01-31 A | 1544010, 1544006 FS-60d | 100% | 2012-08-13 | 2012-12-14 | ELEC TECH [80 h] | 3,599.12 | 3,609.56 |  |  |  |  | 0 | 3530.4 | CHUDAKOV | 1 | 1 | D |  | U | EUGENE C |  |  |  | 10-077 | 11-006 | 11-026 |  |  |  |  |  |  |  | XX |  |  |  |  |  |  |  |  |  |  |  |  |  |  |  |  |  |  |  |  |  |
| 1544080 |  | Re-Baseline Actuals Adjustment | 1d | 2013-08-30 A | 2013-08-30 A |  | 100% | 2013-09-03 | 2013-09-03 | PROCUREMENT>$50K 69 NO ESCALATION | -29,853.89 |  |  |  |  | 100 |  |  |  |  |  |  |  |  |  |  |  |  |  |  |  |  |  |  |  |  |  |  |  |  | ADJ |  |  |  |  |  |  |  |  |  |  |  |  |  |  |  |  |  |  |  |
|  | 5 | **1.5.4.5 LOGIC, HV** |  | 2009-01-02 | 2013-08-30 |  |  |  |  |  |  |  |  |  |  |  |  |  |  |  |  |  |  |  |  |  |  |  |  |  |  |  |  |  |  |  |  |  |  |  |  |  |  |  |  |  |  |  |  |  |  |  |  |  |  |  |  |  |  |  |
| 1545009E |  | FY09 Travel (LOGIC, HV) | 189d | 2009-01-02 A | 2009-09-30 A | 1545009EX | 100% |  |  | TRAVEL | 973.93 |  |  |  |  |  | 0 | 973.93 | CHUDAKOV | 1 | 1 | D |  | E | EUGENE C |  |  |  |  | 11-006 | 11-026 |  |  |  |  |  |  |  |  |  |  | 100 | 100 | 07-024 | 07-027 | 08-058 |  |  |  |  |  |  |  |  |  |  |  |  |  |  |
| 1545050 |  | High Voltage - First Article Crates (QTY 1) and Modules (QTY 10) | 547d | 2009-04-01 A | 2011-06-13 A | 1234180M, 9-110M FS+60d, 1545040 FS-24d | 100% |  |  | PROCUREMENT<$50K 60; PROCUREMENT>$50K 69 | 76,620.04 |  | 0 | 76620.04 | 7662004 | 100 | 0 | 76620.04 | CHUDAKOV | 1 | 1 | D | APP | D | EUGENE C |  | 545 |  |  | 11-006 | 11-026 |  |  |  |  |  |  | 09-012 |  |  |  |  |  |  |  |  | 08-036 | 10-024 | 11-002 |  |  |  |  |  |  |  |  |  |  |  |
| 1545050a |  | High Voltage - First Article Crates (QTY 1) and Modules (added cost) | 549.5d | 2009-04-01 A | 2011-06-16 A | 1545050 FS+37.5d | 100% |  |  | PROCUREMENT>$50K 69 | 2,454 |  | 0 | 2454 | 245400 | 100 | 0 | 2454 | CHUDAKOV | 1 | 1 | D | APP | D | EUGENE C |  | 545 |  |  | 11-006 | 11-026 |  |  |  |  |  |  | 09-012 |  |  |  |  |  |  |  |  | 08-036 | 10-024 | 11-002 |  |  |  |  |  |  |  |  |  |  |  |
| 1545010E |  | FY10 Travel (LOGIC, HV) | 248d | 2009-10-01 A | 2010-09-30 A | 1545009E | 100% |  |  | TRAVEL | 1,208.66 |  |  |  |  |  | 0 | 1208.66447 | CHUDAKOV | 1 | 1 | D |  | E | EUGENE C |  |  |  |  | 11-006 | 11-026 |  |  |  |  |  |  |  |  |  |  | 100 | 100 | 07-024 | 07-027 |  |  |  |  | 11-029 |  |  |  |  |  |  |  |  |  |  |
| 1545011E |  | FY11 Travel (LOGIC, HV) | 248d | 2010-10-01 A | 2011-09-30 A | 1545010E | 100% |  |  | TRAVEL | 1,247.22 |  |  |  |  |  | 0 | 1247.22 | CHUDAKOV | 1 | 1 | D |  | E | EUGENE C |  |  |  |  | 11-006 | 11-026 |  |  |  |  |  |  |  |  |  |  | 100 | 100 | 07-024 | 07-027 |  |  |  |  | 11-029 | 8.46774193 | 91.53225806 |  |  |  |  |  |  |  |  |
| 1545014 |  | Discriminator - First Article Procurement Support | 38d | 2011-02-01 A | 2011-03-25 A | 1234180M, 9-110M FS+63d | 100% |  |  | ELEC ENG [40 h]; ELEC TECH [160 h] | 9,578.4 | 9,578.4 |  |  |  |  | 0 | 9578.4 | CHUDAKOV | 1 | 1 | D | APP | H | EUGENE C |  | 545 |  |  | 11-006 | 11-026 |  |  |  |  |  |  |  |  |  |  |  |  | 07-024 |  |  |  | 10-024 |  |  |  |  | IPL | 09-014 | 10-042 | 12-016 |  |  |  |  |
| 1545040 |  | High Voltage - First Article Procurement Support | 37d | 2011-02-01 A | 2011-03-25 A | 9-110M FS+59d | 100% | 2011-02-01 | 2011-03-24 | ELEC ENG [240 h] | 16,411.2 | 16,411.2 |  |  |  |  | 0 | 16411.2 | CHUDAKOV | 1 | 1 | D |  | H | EUGENE C |  |  |  |  | 11-006 | 11-026 |  |  |  |  |  |  | 09-012 |  |  |  |  |  |  |  |  |  |  |  |  |  |  |  |  |  |  | DUP |  |  |  |
| 1545015 |  | Discriminator - First Article Parts Fab and Assembly (QTY 25) | 147d | 2011-03-01 A | 2011-09-26 A | 1545014 FS-45d, 1234180M | 100% |  |  | PROCUREMENT>$50K 69 NO ESCALATION FY12; PROCUREMENT<$50K 60 NO ESCALATION FY12 | 62,500 |  | 0 | 62500 | 6250000 | 100 | 0 | 62500 | CHUDAKOV | 1 | 1 | D | APP | D | EUGENE C |  | 545 |  |  | 11-006 | 11-026 |  |  |  |  |  |  |  |  |  |  |  |  | 07-024 |  |  |  | 10-024 |  |  |  |  | IPL | 09-014 | 10-042 | 12-016 |  |  |  |  |
| 1545017 |  | Test stand for testing/acceptance of discriminator | 19d | 2011-03-01 A | 2011-03-25 A | 9-110M FS+120d | 100% |  |  | ELEC ENG [200 h]; SCIENTIST [200 h] | 27,362 | 27,362 |  |  |  |  | 0 | 27362 | CHUDAKOV | 1 | 1 | D |  | D | EUGENE C |  |  |  |  | 11-006 | 11-026 |  |  |  |  |  |  | 09-012 |  |  |  |  |  | 07-024 |  |  |  |  |  |  |  |  |  |  |  | 12-016 | DUP | 09-045 |  |  |
| 1545090 |  | Low Voltage - First Article Procurement Support | 43d | 2011-05-02 A | 2011-06-30 A | 9-110M FS+101d | 100% |  |  | ELEC ENG [240 h] | 16,411.2 | 16,411.2 |  |  |  |  | 0 | 16411.2 | CHUDAKOV | 1 | 1 | D |  | H | EUGENE C |  |  |  |  | 11-006 | 11-026 | 12-021F |  |  |  |  |  | 09-012 |  |  |  |  |  |  |  |  |  |  |  |  |  |  |  |  |  |  | DUP |  |  |  |
| 1545095 |  | Low Voltage - First Article Crates (QTY 1) | 38d | 2011-06-01 A | 2011-07-25 A | 1545090 FS-108d, 9-110M FS+60d | 100% |  |  | PROCUREMENT<$50K 60 | 6,300 |  | 0 | 6300 | 630000 | 100 | 0 | 6300 | CHUDAKOV | 1 | 1 | D | APP | D | EUGENE C |  | 545 |  |  | 11-006 | 11-026 | 12-021F |  |  |  |  |  | 09-012 |  |  |  |  |  |  |  |  | 08-036 | 10-024 | 11-002 |  |  |  |  |  |  |  |  |  |  |  |
| 1545097 |  | Low Voltage - First Article Modules (QTY 8) | 173d | 2011-06-01 A | 2012-02-13 A | 1545090 FS-108d, 9-110M FS+60d | 100% |  |  | PROCUREMENT<$50K 60 | 45,200 |  | 0 | 45200 | 4520000 | 100 | 0 | 45200 | CHUDAKOV | 1 | 1 | D | APP | D | EUGENE C |  | 545 |  |  | 11-006 | 11-026 | 12-021F |  |  |  |  |  | 09-012 |  |  |  |  |  |  |  |  | 08-036 | 10-024 | 11-002 |  |  |  |  |  |  |  |  |  |  |  |
| 1545051 |  | High Voltage - First Article Crates Acceptance Tests (QTY 1) | 16d | 2011-07-01 A | 2011-07-25 A | 1545050 FS+9d, 1545050a FS-60d | 100% |  |  | ELEC ENG [40 h]; ELEC TECH [40 h] | 4,446 | 4,446 |  |  |  |  | 0 | 4446 | CHUDAKOV | 1 | 1 | D | APP | H | EUGENE C |  | 545 |  |  | 11-006 | 11-026 |  |  |  |  |  |  | 09-012 |  |  |  |  |  |  |  |  | 08-036 | 10-024 | 11-002 |  |  |  |  |  |  |  |  |  |  |  |
| 1545098 |  | Low Voltage - First Article Crates Acceptance Tests (QTY 1) | 50d | 2011-07-18 A | 2011-09-26 A | 1545095 | 100% |  |  | ELEC ENG [40 h]; ELEC TECH [40 h] | 4,446 | 4,446 |  |  |  |  | 0 | 4446 | CHUDAKOV | 1 | 1 | D | APP | H | EUGENE C |  | 545 |  |  | 11-006 | 11-026 | 12-021F |  |  |  |  |  | 09-012 |  |  |  |  |  |  |  |  | 08-036 | 10-024 | 11-002 |  |  |  |  |  |  |  |  |  |  |  |
| 1545055 |  | High Voltage - First Article Modules Acceptance Tests (QTY 10) | 7d | 2011-07-19 A | 2011-07-27 A | 1545051 FS-5d, 1545050, 1545050a FS-50d | 100% |  |  | ELEC ENG [40 h]; ELEC TECH [120 h] | 7,867.6 | 7,867.6 |  |  |  |  | 0 | 7867.6 | CHUDAKOV | 1 | 1 | D | APP | H | EUGENE C | 08-035 | 545 |  |  | 11-006 | 11-026 |  |  |  |  |  |  |  |  |  |  |  |  | 07-024 |  |  |  | 10-024 |  |  |  |  |  |  |  |  |  |  | 10-054 |  |
| 1545025 |  | Discriminator - Production Procurement Support | 98d | 2011-08-01 A | 2011-12-19 A | 1545022 FS-150d, 9-120M FS-21d | 100% |  |  | ELEC TECH [400 h] | 17,407.76 | 17,407.76 |  |  |  |  | 0 | 17652 | CHUDAKOV | 1 | 1 | D |  | H | EUGENE C |  |  |  |  | 11-006 | 11-026 |  |  |  |  |  |  |  |  |  |  |  |  | 07-024 | 07-027 |  |  |  |  |  |  |  |  | 09-014 | 10-042 | 12-016 |  |  |  |  |
| 1545022 |  | Discriminator - Full Single-Crate Acceptance Test | 6d | 2011-09-19 A | 2011-09-26 A | 1545020a FS-43d, 1545020 FS-43d | 100% |  |  | ELEC TECH [160 h]; ELEC ENG [40 h] | 9,578.4 | 9,578.4 |  |  |  |  | 0 | 9883.2 | CHUDAKOV | 1 | 1 | D |  | H | EUGENE C |  |  |  |  | 11-006 | 11-026 |  |  |  |  |  |  |  |  |  |  |  |  | 07-024 | 07-027 |  |  |  |  |  |  |  |  | 09-014 | 10-042 | 12-016 |  |  |  |  |
| 1545105 |  | Low Voltage - Production Procurement Support | 6d | 2011-09-19 A | 2011-09-26 A | 1545100 FS-30d | 100% |  |  | ELEC ENG [40 h] | 2,735.2 | 2,735.2 |  |  |  |  | 0 | 2822.4 | CHUDAKOV | 1 | 1 | D |  | H | EUGENE C |  |  |  |  | 11-006 | 11-026 | 12-021F |  |  |  |  |  |  |  |  |  |  |  | 07-024 | 07-027 |  |  |  | 11-002 |  |  |  |  |  |  |  |  |  |  |  |
| 1545020 |  | Discriminator - First Article Test (QTY 25) FY11 | 20.96d | 2011-09-26 A | 2011-10-24 A | 1545017, 1545015 | 100% |  |  | ELEC ENG [20.17 h]; ELEC TECH [242.05 h] | 12,015.86 | 12,015.86 |  |  |  |  | 0 | 11731.7031 | CHUDAKOV | 1 | 1 | D |  | U | EUGENE C |  |  |  |  | 11-006 | 11-026 |  |  |  | 12-001 |  |  |  |  |  |  |  |  | 07-024 | 07-027 |  |  |  |  |  |  |  |  | 09-014 | 10-042 | 12-016 |  |  |  |  |
| 1545020a |  | Discriminator - First Article Test (QTY 25) FY12 | 21d | 2011-09-26 A | 2011-10-24 A | 1545020 FS-140d | 100% |  |  | ELEC ENG [19.83 h]; ELEC TECH [237.95 h] | 11,812.59 | 11,812.59 |  |  |  |  | 0 | 11899.9383 | CHUDAKOV | 1 | 1 | D |  | U | EUGENE C |  |  |  |  | 11-006 | 11-026 |  |  |  | 12-001 |  |  |  |  |  |  |  |  | 07-024 | 07-027 |  |  |  |  |  |  |  |  | 09-014 | 10-042 | 12-016 |  |  |  |  |
| 1545100 |  | Low Voltage - First Article Modules Acceptance Tests (QTY 10) | 116d | 2011-09-26 A | 2012-03-19 A | 1545098, 1545097 FS-210d | 100% |  |  | ELEC ENG [40 h]; ELEC TECH [120 h] | 8,107.21 | 8,107.21 |  |  |  |  | 0 | 7867.6 | CHUDAKOV | 1 | 1 | D | APP | H | EUGENE C | 08-035 | 545 |  |  | 11-006 | 11-026 | 12-021F |  |  |  |  |  |  |  |  |  |  |  | 07-024 |  |  |  | 10-024 |  |  |  |  |  |  |  |  |  |  | 10-054 |  |
| 1545110 |  | Low Voltage - Crates Production (QTY 7) | 116d | 2011-09-26 A | 2012-03-19 A | 9-120M FS-30d, 1545105 FS-51d | 100% |  |  | PROCUREMENT<$50K 60 NO ESCALATION FY13 | 45,506.79 |  | 0 | 45506.79 | 4550679 | 100 | 0 | 45506.79 | CHUDAKOV | 1 | 1 | D |  | D | EUGENE C |  |  |  |  | 11-006 | 11-026 | 12-021 |  |  |  |  |  |  |  |  |  |  |  | 07-024 | 07-027 |  |  |  | 11-002 |  |  |  |  |  |  |  |  |  |  |  |
| 1545115 |  | Low Voltage - Modules Production (QTY 38) | 156d | 2011-09-26 A | 2012-05-14 A | 1545110 FS-190d, 9-120M FS-30d | 100% |  |  | PROCUREMENT<$50K 60 NO ESCALATION FY13; PROCUREMENT>$50K 69 NO ESCALATION FY13 | 195,235.48 |  | 0 | 195235.48 | 19523548 | 100 | 0 | 195235.48 | CHUDAKOV | 1 | 1 | D |  | D | EUGENE C |  |  |  |  | 11-006 | 11-026 | 12-021 |  |  |  |  |  |  |  |  |  |  |  |  |  |  |  |  |  |  |  |  |  |  |  |  |  |  |  |  |
| 1545005 |  | Assemble Signal Distrbtn CFD Tests (LOGIC, HV) | 11d | 2011-10-03 A | 2011-10-17 A | 1234180M, 9-120M | 100% |  |  |  |  |  |  |  |  |  |  | 0 | CHUDAKOV | 1 | 1 | D |  | Z | EUGENE C |  |  |  |  | 11-006 | 11-026 |  |  |  |  |  |  | 09-012 |  |  |  |  |  | 07-024 |  |  |  |  |  |  |  |  |  |  |  |  | DUP |  |  |  |
| 1545060 |  | High Voltage - Production Procurement Support | 30d | 2011-10-03 A | 2011-11-14 A | 9-120M, 1545055 | 100% | 2011-10-03 | 2011-11-11 | ELEC TECH [40 h] | 1,765.2 | 1,765.2 |  |  |  |  | 0 | 1765.2 | CHUDAKOV | 1 | 1 | D |  | H | EUGENE C |  |  |  |  | 11-006 | 11-026 |  |  |  |  |  |  |  |  |  |  |  |  | 07-024 | 07-027 |  |  |  | 11-002 |  |  |  |  |  |  |  |  |  |  |  |
| 1545010 |  | Dry Run of Testing Procedures for CFDs (LOGIC, HV) | 5d | 2011-10-17 A | 2011-10-21 A | 1545005 | 100% |  |  |  |  |  |  |  |  |  |  | 0 | CHUDAKOV | 1 | 1 | D |  | Z | EUGENE C |  |  |  |  | 11-006 | 11-026 |  |  |  |  |  |  | 09-012 |  |  |  |  |  | 07-024 |  |  |  |  |  | 11-029 |  |  |  |  |  |  | DUP |  |  |  |
| 1545065 |  | Vend Fab - Universal Multichannel Power Supply System 750W (QTY 6) | 130d | 2011-11-01 A | 2012-05-14 A | 9-120M, 1545060 FS-100d, 1545011E | 100% |  |  | PROCUREMENT<$50K 60; PROCUREMENT>$50K 69 | 52,213.13 |  | 0 | 52213.13 | 5221313 | 100 | 0 | 52213.13 | CHUDAKOV | 1 | 1 | D |  | D | EUGENE C |  |  |  |  | 11-006 | 11-026 |  |  |  |  |  |  |  |  |  |  |  |  | 07-024 | 07-027 |  |  |  | 11-002 |  |  |  |  |  |  |  |  |  |  |  |
| 1545070 |  | Vend Fab - H.V Channels -3.5 KV 3 MA SHV Floating (QTY 18) | 33d | 2011-11-01 A | 2011-12-19 A | 1545066 FS-130d | 100% |  |  | PROCUREMENT>$50K 69 | 124,270.13 |  | 0 | 124270.13 | 12427013 | 100 | 0 | 124270.13 | CHUDAKOV | 1 | 1 | D |  | D | EUGENE C |  |  |  |  | 11-006 | 11-026 |  |  |  |  |  |  |  |  |  |  |  |  |  |  |  |  |  |  |  |  |  |  |  |  |  |  |  |  |  |
| 1545071 |  | Vend Fab - H.V Channels +3.5 KV 3 MA Floating (QTY 8) | 66d | 2011-11-01 A | 2012-02-13 A | 1545070 FS-130d | 100% |  |  | PROCUREMENT>$50K 69 | 55,981.65 |  | 0 | 55981.65 | 5598165 | 100 | 0 | 55981.65 | CHUDAKOV | 1 | 1 | D |  | D | EUGENE C |  |  |  |  | 11-006 | 11-026 |  |  |  |  |  |  |  |  |  |  |  |  |  |  |  |  |  |  |  |  |  |  |  |  |  |  |  |  |  |
| 1545075 |  | Vend Fab - H.V Channels -3.5 KV 3 MA Floating (QTY 3) | 33d | 2011-11-01 A | 2011-12-19 A | 1545071 FS-130d | 100% |  |  | PROCUREMENT>$50K 69 | 21,677.11 |  | 0 | 21677.11 | 2167711 | 100 | 0 | 21677.11 | CHUDAKOV | 1 | 1 | D |  | D | EUGENE C |  |  |  |  | 11-006 | 11-026 |  |  |  |  |  |  |  |  |  |  |  |  |  |  |  |  |  |  |  |  |  |  |  |  |  |  |  |  |  |
| 1545066 |  | Vend Fab - Optional Power Supply 750W (QTY 6) | 110d | 2011-12-01 A | 2012-05-14 A | 1545065 FS-130d | 100% |  |  | PROCUREMENT>$50K 69 | 8,210.85 |  | 0 | 8210.85 | 821085 | 100 | 0 | 8210.85 | CHUDAKOV | 1 | 1 | D |  | D | EUGENE C |  |  |  |  | 11-006 | 11-026 |  |  |  |  |  |  |  |  |  |  |  |  | 07-024 | 07-027 |  |  |  | 11-002 |  |  |  |  |  |  |  |  |  |  |  |
| 1545026 |  | Discriminator - Production Parts Non-Recurring Engineering | 92d | 2012-01-03 A | 2012-05-14 A | 9-120M FS+59d | 100% | 2012-01-03 | 2012-05-11 | PROCUREMENT<$50K 60 NO ESCALATION; PROCUREMENT>$50K 69 NO ESCALATION | 750.6 |  | 0 | 750.6 | 75060 | 100 | 0 | 750.6 | CHUDAKOV | 1 | 1 | D |  | D | EUGENE C |  |  |  |  |  |  |  |  |  |  |  |  |  |  |  |  |  |  |  |  |  |  |  |  |  |  |  |  |  |  | 12-016 |  |  |  |  |
| 1545027 |  | Discriminator - Production Parts Fab and Assembly (QTY 70) | 156d | 2012-01-03 A | 2012-08-13 A | 1545026 FS-104d, 1545025 | 100% |  |  | PROCUREMENT<$50K 60 NO ESCALATION; PROCUREMENT>$50K 69 NO ESCALATION | 103,125.7 |  | 0 | 103125.7 | 10312570 | 100 | 0 | 103125.7 | CHUDAKOV | 1 | 1 | D |  | D | EUGENE C |  |  |  |  | 11-006 | 11-026 |  |  |  |  |  |  |  |  |  |  |  |  | 07-024 | 07-027 |  |  |  |  |  |  |  |  | 09-014 | 10-042 | 12-016 |  |  |  |  |
| 1545125 |  | Low Voltage - Modules Production Tests (QTY 38) FY12 | 215.3d | 2012-01-09 A | 2012-11-12 A | 1545115 FS-190d | 100% |  |  | ELEC TECH [265.48 h] | 11,768.3 | 11,768.31 |  |  |  |  | 0 | 11715.6324 | CHUDAKOV | 1 | 1 | D |  | U | EUGENE C |  |  |  |  | 11-006 | 11-026 | 12-021 |  |  |  |  |  |  |  |  |  |  |  |  |  |  |  |  |  |  |  |  |  |  |  |  |  |  |  | 12-053 |
| 1545125a |  | Low Voltage - Modules Production Tests (QTY 38) FY13 | 216d | 2012-01-09 A | 2012-11-12 A | 1545125 FS-45d | 100% |  |  | ELEC TECH [54.52 h] | 2,417 | 2,417 |  |  |  |  | 0 | 2482.8408 | CHUDAKOV | 1 | 1 | D |  | U | EUGENE C |  |  |  |  | 11-006 | 11-026 | 12-021 |  |  |  |  |  |  |  |  |  |  |  |  |  |  |  |  |  |  |  |  |  |  |  |  |  |  |  | 12-053 |
| 1545080 |  | High Voltage - Crates Production Tests (QTY 6) | 211d | 2012-01-16 A | 2012-11-12 A | 1545066 FS-120d, 1545065 FS-80d | 100% | 2012-01-17 | 2012-11-12 | ELEC TECH [80 h] | 3,546.97 | 3,546.97 |  |  |  |  | 0 | 3530.4 | CHUDAKOV | 1 | 1 | D |  | U | EUGENE C |  |  |  |  | 11-006 | 11-026 |  |  |  |  |  |  |  |  |  |  |  |  |  |  |  |  |  |  |  |  |  |  |  |  |  |  |  |  |  |
| 1545120 |  | Low Voltage - Crates Production Tests (QTY 7) FY12 | 73d | 2012-02-01 A | 2012-05-14 A | 1545110 FS-1750d | 100% |  |  | ELEC TECH [66.37 h] | 2,928.91 | 2,928.91 |  |  |  |  | 0 | 2928.9081 | CHUDAKOV | 1 | 1 | D |  | U | EUGENE C |  |  |  |  | 11-006 | 11-026 | 12-021 |  |  |  |  |  |  |  |  |  |  |  |  |  |  |  |  |  |  |  |  |  |  |  |  |  |  |  | 12-053 |
| 1545120a |  | Low Voltage - Crates Production Tests (QTY 7) FY13 | 73d | 2012-02-01 A | 2012-05-14 A | 1545120 | 100% |  |  | ELEC TECH [13.63 h] | 601.49 | 601.49 |  |  |  |  | 0 | 620.7102 | CHUDAKOV | 1 | 1 | D |  | U | EUGENE C |  |  |  |  | 11-006 | 11-026 | 12-021 |  |  |  |  |  |  |  |  |  |  |  |  |  |  |  |  |  |  |  |  |  |  |  |  |  |  |  | 12-053 |
| 1545085 |  | High Voltage - Modules Production Tests (QTY 29) | 167d | 2012-02-20 A | 2012-10-15 A | 1545075 FS-38d | 100% | 2012-02-21 | 2012-10-15 | ELEC TECH [320 h] | 14,151.32 | 14,151.32 |  |  |  |  | 0 | 14121.6 | CHUDAKOV | 1 | 1 | D |  | U | EUGENE C |  |  |  |  | 11-006 | 11-026 |  |  |  |  |  |  |  |  |  |  |  |  |  |  |  |  |  |  |  |  |  |  |  |  |  |  |  |  |  |
| 1545030 |  | Discriminator - Production Test (QTY 70) FY12 | 96.47d | 2012-05-01 A | 2012-09-17 A | 1545027 FS-80d, 1545010 | 100% |  |  | ELEC TECH [157.24 h] | 6,939 | 6,939 |  |  |  |  | 0 | 6939.0012 | CHUDAKOV | 1 | 1 | D |  | U | EUGENE C |  |  |  |  | 11-006 | 11-026 |  |  |  |  |  |  |  |  |  |  |  |  | 07-024 | 07-027 |  |  |  |  |  |  |  |  | 09-014 | 10-042 | 12-016 |  |  |  | 12-053 |
| 1545028 |  | Procure Discriminators (Qty.24) Supplemental BCAL and PS | 73d | 2012-05-01 A | 2012-08-13 A | 9-120M | 100% |  |  | PROCUREMENT<$50K 60 NO ESCALATION FY13 | 48,000 |  | 0 | 48000 | 4800000 | 100 | 0 | 48000 | CHUDAKOV | 1 | 1 | D |  | D | EUGENE C |  |  |  |  | 11-006 | 11-026 | 12-021 |  |  |  |  |  |  |  |  |  |  |  |  |  |  |  |  |  |  |  |  |  |  |  |  |  |  |  |  |
| 1545030a |  | Discriminator - Production Test (QTY 70) FY13 | 97d | 2012-05-01 A | 2012-09-17 A | 1545030 FS-60d | 100% |  |  | ELEC TECH [322.76 h] | 14,243.4 | 14,243.4 |  |  |  |  | 0 | 14698.4904 | CHUDAKOV | 1 | 1 | D |  | U | EUGENE C |  |  |  |  | 11-006 | 11-026 |  |  |  |  |  |  |  |  |  |  |  |  | 07-024 | 07-027 |  |  |  |  |  |  |  |  | 09-014 | 10-042 | 12-016 |  |  |  | 12-053 |
| 1545130 |  | Re-Baseline Actuals Adjustment | 1d | 2013-08-30 A | 2013-08-30 A |  | 100% | 2013-09-03 | 2013-09-03 | PROCUREMENT>$50K 69 NO ESCALATION | -218,552.68 |  |  |  |  | 100 |  |  |  |  |  |  |  |  |  |  |  |  |  |  |  |  |  |  |  |  |  |  |  |  | ADJ |  |  |  |  |  |  |  |  |  |  |  |  |  |  |  |  |  |  |  |

Notes:
- 1545014: Explanation: IPL from 6 GeV 5545040M
- 1545015: Explanation: IPL from 6 GeV 5545040M

| ID | WBS | Activity | Duration | Start | Finish | Predecessors | Complete | Planned start | Planned finish | Resources | Cost | Actual cost | Calculated Remaining Total Cost | MONTHLY EV COST | RESP - Responsibility | STRT%COMP for CM EVM | FNSH%COMP for CM EVM | HALL D Related Milestones | EVMS Reporting Codes | CAM RESPONSIBLE | CR 11-006 | CR 11-026 | CR 12-054 | Remaining Material Cost Based on % Compl | Claimed Material Cost Based on % Complet | Initial Claimed Material Calc | Claimed Material Divider | CR 12-001 | CR 12-021 | MARCH!!! | New H Claim | CR 12-053 |
| --- | --- | --- | --- | --- | --- | --- | --- | --- | --- | --- | --- | --- | --- | --- | --- | --- | --- | --- | --- | --- | --- | --- | --- | --- | --- | --- | --- | --- | --- | --- | --- | --- |
|  | 6 | **1.5.4.6 DETECTOR ELECTRONICS** |  | 2011-01-05 | 2014-09-30 |  |  |  |  |  |  |  |  |  |  |  |  |  |  |  |  |  |  |  |  |  |  |  |  |  |  |  |
| 1546005 |  | ASIC - Procurement Support (FDC&CDC) | 32d | 2011-01-05 A | 2011-02-21 A | 9-110M FS+59d | 100% | 2011-01-05 | 2011-02-18 | ELEC ENG [200 h] | 13,676 | 13,676 | 0 | 13676 | CHUDAKOV | 1 | 1 | D | H | EUGENE C | 11-006 | 11-026 | 12-054F |  |  |  |  |  |  |  |  |  |
| 1546020 |  | ASIC - Test Fixture Development (FDC&CDC) | 19d | 2011-02-01 A | 2011-02-28 A | 9-110M FS+68d | 100% |  |  | ELEC ENG [40 h]; ELEC TECH [240 h] | 13,000 | 13,000 | 0 | 13000 | CHUDAKOV | 1 | 1 | D | H | EUGENE C | 11-006 | 11-026 | 12-054F |  |  |  |  |  |  |  |  |  |
| 1546125 |  | HVB - Development Revisions (CDC) | 19d | 2011-02-01 A | 2011-02-28 A | 9-110M FS+72d | 100% |  |  | ELEC ENG [160 h] | 10,940.8 | 10,940.8 | 0 | 10940.8 | CHUDAKOV | 1 | 1 | D | H | EUGENE C | 11-006 | 11-026 | 12-054F |  |  |  |  |  |  |  |  |  |
| 1546140 |  | HVB - First Article Procurement Support (CDC) | 106d | 2011-02-01 A | 2011-06-30 A | 9-110M FS+72d | 100% |  |  | ELEC ENG [40 h]; ELEC TECH [80 h] | 6,156.8 | 6,156.8 | 0 | 6156.8 | CHUDAKOV | 1 | 1 | D | H | EUGENE C | 11-006 | 11-026 | 12-054F |  |  |  |  |  |  |  |  |  |
| 1546145 |  | HVB - First Article Parts (CDC) | 106d | 2011-02-01 A | 2011-06-30 A | 1546140 FS-59d | 100% |  |  | PROCUREMENT<$50K 60 | 10,000 |  | 0 | 10000 | CHUDAKOV | 1 | 1 | D | D | EUGENE C | 11-006 | 11-026 | 12-054F | 0 | 10000 | 1000000 | 100 |  |  |  |  |  |
| 1546025 |  | ASIC - Test Fixture Procurement Support (FDC&CDC) | 87d | 2011-03-01 A | 2011-06-30 A | 1546020 | 100% |  |  | ELEC TECH [80 h] | 3,421.6 | 3,421.6 | 0 | 3421.6 | CHUDAKOV | 1 | 1 | D | H | EUGENE C | 11-006 | 11-026 | 12-054F |  |  |  |  |  |  |  |  |  |
| 1546030 |  | ASIC - Test Fixture Parts (FDC&CDC) | 60d | 2011-03-01 A | 2011-05-23 A | 1546020 | 100% |  |  | PROCUREMENT<$50K 60 | 10,000 |  | 0 | 10000 | CHUDAKOV | 1 | 1 | D | H | EUGENE C | 11-006 | 11-026 | 12-054F | 0 | 10000 | 1000000 | 100 |  |  |  |  |  |
| 1546095 |  | Preamp Card - Test Fixture Development (FDC&CDC) | 130d | 2011-03-01 A | 2011-08-31 A | 9-110M FS+111d | 100% |  |  | ELEC TECH [240 h]; ELEC ENG [40 h] | 13,000 | 13,000 | 0 | 13000 | CHUDAKOV | 1 | 1 | D | H | EUGENE C | 11-006 | 11-026 | 12-054F |  |  |  |  |  |  |  |  |  |
| 1546130 |  | HVB - Development PCB Fab Files (CDC) | 11d | 2011-04-02 A | 2011-04-18 A | 1546125 FS-9d | 100% | 2011-04-04 | 2011-04-18 | ELEC ENG [40 h] | 2,735.2 | 2,735.2 | 0 | 2735.2 | CHUDAKOV | 1 | 1 | D | H | EUGENE C | 11-006 | 11-026 | 12-054F |  |  |  |  |  |  |  |  |  |
| 1546135 |  | HVB - Development PCB Assembly Files (CDC) | 63d | 2011-04-02 A | 2011-06-30 A | 1546130 FS-5d, 1546125 FS-9d | 100% | 2011-04-04 | 2011-06-30 | ELEC ENG [40 h] | 2,735.2 | 2,735.2 | 0 | 2735.2 | CHUDAKOV | 1 | 1 | D | H | EUGENE C | 11-006 | 11-026 | 12-054F |  |  |  |  |  |  |  |  |  |
| 1546150 |  | HVB - First Article Fab 2 Units (CDC) | 25d | 2011-04-04 A | 2011-05-08 A | 1546135 FS-5d, 1546145 FS-90d | 100% | 2011-04-04 | 2011-05-06 | PROCUREMENT<$50K 60 | 2,000 |  | 0 | 2000 | CHUDAKOV | 1 | 1 | D | H | EUGENE C | 11-006 | 11-026 | 12-054F | 0 | 2000 | 200000 | 100 |  |  |  |  |  |
| 1546035 |  | ASIC - Test Fixture Fab (FDC&CDC) | 13d | 2011-04-11 A | 2011-04-27 A | 1546030 | 100% |  |  | PROCUREMENT<$50K 60 | 2,000 |  | 0 | 2000 | CHUDAKOV | 1 | 1 | D | H | EUGENE C | 11-006 | 11-026 | 12-054F | 0 | 2000 | 200000 | 100 |  |  |  |  |  |
| 1546155 |  | HVB - First Article Assembly 2 Units (CDC) | 38d | 2011-05-09 A | 2011-06-30 A | 1546150 | 100% |  |  | ELEC TECH [40 h] | 1,710.8 | 1,710.8 | 0 | 1710.8 | CHUDAKOV | 1 | 1 | D | H | EUGENE C | 11-006 | 11-026 | 12-054F |  |  |  |  |  |  |  |  |  |
| 1546160 |  | HVB - First Article Test 2 Units (CDC) | 33d | 2011-05-15 A | 2011-06-30 A | 1546155 FS-15d | 100% | 2011-05-16 | 2011-06-30 | ELEC TECH [40 h] | 1,710.8 | 1,710.8 | 0 | 1710.8 | CHUDAKOV | 1 | 1 | D | H | EUGENE C | 11-006 | 11-026 | 12-054F |  |  |  |  |  |  |  |  |  |
| 1546040 |  | ASIC - Test Fixture Assembly (FDC&CDC) | 33d | 2011-05-16 A | 2011-06-30 A | 1546035, 1546025 FS-20d | 100% |  |  | ELEC TECH [80 h] | 3,421.6 | 3,421.6 | 0 | 3421.6 | CHUDAKOV | 1 | 1 | D | H | EUGENE C | 11-006 | 11-026 | 12-054F |  |  |  |  |  |  |  |  |  |
| 1546045 |  | ASIC - Test Fixture Test (FDC&CDC) | 33d | 2011-05-16 A | 2011-06-30 A | 1546040 FS-20d | 100% |  |  | ELEC TECH [80 h]; ELEC ENG [40 h] | 6,156.8 | 6,156.8 | 0 | 6156.8 | CHUDAKOV | 1 | 1 | D | H | EUGENE C | 11-006 | 11-026 | 12-054F |  |  |  |  |  |  |  |  |  |
| 1546050 |  | Preamp Card - First Article Procurement Support (FDC&CDC) | 41d | 2011-06-01 A | 2011-07-28 A | 9-110M FS+126d | 100% |  |  | ELEC TECH [200 h]; ELEC ENG [40 h] | 11,289.2 | 11,289.2 | 0 | 11289.2 | CHUDAKOV | 1 | 1 | D | H | EUGENE C | 11-006 | 11-026 | 12-054F |  |  |  |  |  |  |  |  |  |
| 1546055 |  | Preamp Card - First Article Parts (FDC&CDC) | 22d | 2011-06-01 A | 2011-06-30 A | 1546050 FS-60d, 9-110M FS+126d | 100% |  |  | PROCUREMENT<$50K 60 | 25,000 |  | 0 | 25000 | CHUDAKOV | 1 | 1 | D | D | EUGENE C | 11-006 | 11-026 | 12-054F | 0 | 25000 | 2500000 | 100 |  |  |  |  |  |
| 1546165 |  | HVB - Production Procurement Support (CDC) | 38d | 2011-06-01 A | 2011-07-25 A | 1546160 | 100% |  |  | ELEC TECH [80 h]; ELEC ENG [160 h] | 14,362.4 | 14,362.4 | 0 | 14362.4 | CHUDAKOV | 1 | 1 | D | H | EUGENE C | 11-006 | 11-026 | 12-054F |  |  |  |  |  |  |  |  |  |
| 1546185 |  | HVB - Test Fixture Development (CDC) | 65d | 2011-06-01 A | 2011-08-31 A | 9-110M FS+160d | 100% |  |  | ELEC TECH [40 h]; ELEC ENG [40 h] | 4,446 | 4,446 | 0 | 4446 | CHUDAKOV | 1 | 1 | D | H | EUGENE C | 11-006 | 11-026 | 12-054F |  |  |  |  |  |  |  |  |  |
| 1546075 |  | Preamp Card - Production Procurement Support (FDC&CDC) | 11d | 2011-07-11 A | 2011-07-25 A | 1546070a FS-65d | 100% |  |  | ELEC TECH [80 h] | 3,421.6 | 3,421.6 | 0 | 3530.4 | CHUDAKOV | 1 | 1 | D | H | EUGENE C | 11-006 | 11-026 | 12-054F |  |  |  |  |  |  |  |  |  |
| 1546060 |  | Preamp Card - First Article Fab (FDC&CDC) | 45d | 2011-07-18 A | 2011-09-19 A | 1546055 FS+25d | 100% |  |  | PROCUREMENT<$50K 60 | 3,500 |  | 0 | 3500 | CHUDAKOV | 1 | 1 | D | D | EUGENE C | 11-006 | 11-026 | 12-054F | 0 | 3500 | 350000 | 100 |  |  |  |  |  |
| 1546170 |  | HVB - Production Fab (CDC) | 86d | 2011-07-18 A | 2011-11-15 A | 1546165 | 100% |  |  | PROCUREMENT<$50K 60 | 10,000 |  | 0 | 10000 | CHUDAKOV | 1 | 1 | D | D | EUGENE C | 11-006 | 11-026 | 12-054F | 0 | 10000 | 1000000 | 100 |  |  |  |  |  |
| 1546175 |  | HVB - Production Assembly (CDC) | 86d | 2011-07-18 A | 2011-11-15 A | 1546170 FS-25d | 100% |  |  | PROCUREMENT<$50K 60 NO ESCALATION FY12 | 10,000 |  | 0 | 10000 | CHUDAKOV | 1 | 1 | D | D | EUGENE C | 11-006 | 11-026 | 12-054F | 0 | 10000 | 1000000 | 100 |  |  |  |  |  |
| 1546010 |  | ASIC - Test (FDC&CDC) | 23d | 2011-08-01 A | 2011-08-31 A | 1546045, 15211035b FS-15d | 100% |  |  | ELEC ENG [160 h]; ELEC TECH [280 h] | 22,916.4 | 22,916.4 | 0 | 22916.4 | CHUDAKOV | 1 | 1 | D | H | EUGENE C | 11-006 | 11-026 | 12-054F |  |  |  |  |  |  |  |  |  |
| 1546065 |  | Preamp Card - First Article Assembly (FDC&CDC) | 37d | 2011-08-01 A | 2011-09-21 A | 1546060 FS-38d | 100% |  |  | PROCUREMENT<$50K 60 | 5,000 |  | 0 | 5000 | CHUDAKOV | 1 | 1 | D | D | EUGENE C | 11-006 | 11-026 | 12-054F | 0 | 5000 | 500000 | 100 |  |  |  |  |  |
| 1546080 |  | Preamp Card - Production Fab (FDC&CDC) | 60d | 2011-08-01 A | 2011-10-24 A | 1546070a FS-50d, 1546075 FS-101d | 100% |  |  | PROCUREMENT<$50K 60 | 22,701.8 |  | 0 | 22701.8 | CHUDAKOV | 1 | 1 | D | D | EUGENE C | 11-006 | 11-026 | 12-054F | 0 | 22701.8 | 2270180 | 100 |  |  |  |  |  |
| 1546085 |  | Preamp Card - Production Assembly (FDC&CDC) | 56d | 2011-08-01 A | 2011-10-18 A | 1546010 FS-20d, 1546080 FS-40d | 100% |  |  | PROCUREMENT<$50K 60 | 23,733.7 |  | 0 | 23733.7 | CHUDAKOV | 1 | 1 | D | D | EUGENE C | 11-006 | 11-026 | 12-054F | 0 | 23733.7 | 2373370 | 100 |  |  |  |  |  |
| 1546100 |  | Preamp Card - Test Fixture Procurement Support (FDC&CDC) | 23d | 2011-08-01 A | 2011-08-31 A | 1546095 | 100% |  |  | ELEC TECH [80 h] | 3,421.6 | 3,421.6 | 0 | 3421.6 | CHUDAKOV | 1 | 1 | D | H | EUGENE C | 11-006 | 11-026 | 12-054F |  |  |  |  |  |  |  |  |  |
| 1546105 |  | Preamp Card - Test Fixture Parts (FDC&CDC) | 60d | 2011-08-01 A | 2011-10-24 A | 1546100 FS-14d, 1546095 | 100% |  |  | PROCUREMENT<$50K 60 | 10,000 |  | 0 | 10000 | CHUDAKOV | 1 | 1 | D | D | EUGENE C | 11-006 | 11-026 | 12-054F | 0 | 10000 | 1000000 | 100 |  |  |  |  |  |
| 1546110 |  | Preamp Card - Test Fixture Fab (FDC&CDC) | 23d | 2011-08-01 A | 2011-08-31 A | 1546105 FS-20d | 100% |  |  | PROCUREMENT<$50K 60 | 2,000 |  | 0 | 2000 | CHUDAKOV | 1 | 1 | D | P | EUGENE C | 11-006 | 11-026 | 12-054F | 0 | 2000 | 200000 | 100 |  |  |  |  |  |
| 1546115 |  | Preamp Card - Test Fixture Assembly (FDC&CDC) | 23d | 2011-08-01 A | 2011-08-31 A | 1546110 | 100% |  |  | ELEC TECH [80 h] | 3,421.6 | 3,421.6 | 0 | 3421.6 | CHUDAKOV | 1 | 1 | D | H | EUGENE C | 11-006 | 11-026 | 12-054F |  |  |  |  |  |  |  |  |  |
| 1546120 |  | Preamp Card - Test Fixture Test (FDC&CDC) | 23d | 2011-08-01 A | 2011-08-31 A | 1546115 | 100% |  |  | ELEC TECH [80 h] | 3,421.6 | 3,421.6 | 0 | 3421.6 | CHUDAKOV | 1 | 1 | D | H | EUGENE C | 11-006 | 11-026 | 12-054F |  |  |  |  |  |  |  |  |  |
| 1546190 |  | HVB - Test Fixture Procurement Support (CDC) | 23d | 2011-08-01 A | 2011-08-31 A | 1546185 | 100% |  |  | ELEC TECH [40 h] | 1,710.8 | 1,710.8 | 0 | 1710.8 | CHUDAKOV | 1 | 1 | D | H | EUGENE C | 11-006 | 11-026 | 12-054F |  |  |  |  |  |  |  |  |  |
| 1546200 |  | HVB - Test Fixture Fab (CDC) | 23d | 2011-08-01 A | 2011-08-31 A | 1546195 FS-20d | 100% |  |  | PROCUREMENT<$50K 60 | 2,000 |  | 0 | 2000 | CHUDAKOV | 1 | 1 | D | D | EUGENE C | 11-006 | 11-026 | 12-054F | 0 | 2000 | 200000 | 100 |  |  |  |  |  |
| 1546205 |  | HVB - Test Fixture Assembly (CDC) | 23d | 2011-08-01 A | 2011-08-31 A | 1546200 FS-20d | 100% |  |  | ELEC TECH [80 h] | 3,421.6 | 3,421.6 | 0 | 3421.6 | CHUDAKOV | 1 | 1 | D | H | EUGENE C | 11-006 | 11-026 | 12-054F |  |  |  |  |  |  |  |  |  |
| 1546210 |  | HVB - Test Fixture Test (CDC) | 23d | 2011-08-01 A | 2011-08-31 A | 1546205 | 100% |  |  | ELEC TECH [40 h] | 1,710.8 | 1,710.8 | 0 | 1710.8 | CHUDAKOV | 1 | 1 | D | H | EUGENE C | 11-006 | 11-026 | 12-054F |  |  |  |  |  |  |  |  |  |
| 1546195 |  | HVB - Test Fixture Parts (CDC) | 22d | 2011-08-26 A | 2011-09-27 A | 1546185 FS-35d, 1546190 FS-30d | 100% |  |  | PROCUREMENT<$50K 60 | 1,000 |  | 0 | 1000 | CHUDAKOV | 1 | 1 | D | D | EUGENE C | 11-006 | 11-026 | 12-054F | 0 | 1000 | 100000 | 100 |  |  |  |  |  |
| 1546070 |  | Preamp Card - First Article Acceptance QA (FDC&CDC) FY11 | 2d | 2011-09-24 A | 2011-09-27 A | 1546065, 1546120 | 100% | 2011-09-26 | 2011-09-27 | ELEC ENG [16 h]; ELEC TECH [24 h] | 2,120.56 | 2,120.56 | 0 | 2120.56 | CHUDAKOV | 1 | 1 | D | H | EUGENE C | 11-006 | 11-026 | 12-054F |  |  |  |  | 12-001 |  |  |  |  |
| 1546070a |  | Preamp Card - First Article Acceptance QA (FDC&CDC) FY12 | 1d | 2011-09-24 A | 2011-09-26 A | 1546070 | 100% | 2011-09-26 | 2011-09-26 | ELEC ENG [64 h]; ELEC TECH [96 h] | 8,482.24 | 8,482.24 | 0 | 8752.32 | CHUDAKOV | 1 | 1 | D | H | EUGENE C | 11-006 | 11-026 | 12-054F |  |  |  |  | 12-001 |  |  |  |  |
| 1546090 |  | Preamp Card - Production Tests (FDC&CDC) | 179d | 2011-10-17 A | 2012-07-09 A | 1546085, 1546120 | 100% |  |  | ELEC TECH [880 h] | 38,834.4 | 38,834.4 | 0 | 38834.4 | CHUDAKOV | 1 | 1 | D | U | EUGENE C | 11-006 | 11-026 | 12-054F |  |  |  |  |  |  |  |  |  |
| 1546180 |  | HVB - Production Test (CDC) | 55d | 2011-11-16 A | 2012-02-13 A | 1546210, 1546175 | 100% |  |  | ELEC TECH [320 h]; ELEC ENG [40 h] | 16,944 | 16,944 | 0 | 16944 | CHUDAKOV | 1 | 1 | D | U | EUGENE C | 11-006 | 11-026 | 12-054F |  |  |  |  |  |  |  |  |  |
| 1546390 |  | Power Distribution Engineering | 53d | 2012-03-01 A | 2012-05-14 A | 9-120M FS+95d | 100% |  |  | ELEC ENG [136 h] | 9,596.16 | 9,596.16 | 0 | 9596.16 | CHUDAKOV | 1 | 1 | D | H | EUGENE C | 11-006 | 11-026 |  |  |  |  |  |  | 12-021 |  |  |  |
| 1546400 |  | Pair Spectrometer Engineering | 216d | 2012-03-01 A | 2013-07-15 A | 9-120M FS+110d | 100% | 2012-03-01 | 2013-01-11 | ELEC ENG [96 h] | 6,840.76 | 6,895.93 | 3386.88 | 6773.76 | CHUDAKOV | 1 | 1 | D | H | EUGENE C | 11-006 | 11-026 |  |  |  |  |  |  | 12-021 | XX |  |  |
| 1546500 |  | Start Counter Engineering | 53d | 2012-03-01 A | 2012-05-14 A | 9-120M FS+95d | 100% |  |  | ELEC ENG [136 h] | 9,596.16 | 9,596.16 | 0 | 9596.16 | CHUDAKOV | 1 | 1 | D | H | EUGENE C | 11-006 | 11-026 |  |  |  |  |  |  | 12-021 |  |  |  |
| 1546182 |  | Testing/manufacturing equipment for electronic boards | 120d | 2012-03-02 A | 2012-08-20 A | 9-120M FS+100d | 100% |  |  | PROCUREMENT<$50K 60 | 5,000 |  | 0 | 5000 | CHUDAKOV | 1 | 1 | D | H | EUGENE C | 11-006 | 11-026 |  | 0 | 5000 | 500000 | 100 |  | 12-021 |  |  |  |
| 1546445 |  | Pair Spectrometer Power Supplies Procurement Prep | 10d | 2012-03-06 A | 2012-03-19 A | 1546400 FS-40d, 9-120M | 100% |  |  | ELEC ENG [96 h] | 6,773.76 | 6,773.76 | 0 | 6773.76 | CHUDAKOV | 1 | 1 | D | H | EUGENE C | 11-006 | 11-026 |  |  |  |  |  |  | 12-021 |  |  |  |
| 1546505 |  | Start Counter Prototype Procurement Prep | 21d | 2012-04-16 A | 2012-05-14 A | 1546500 FS-15d | 100% |  |  | ELEC ENG [68 h] | 4,798.08 | 4,798.08 | 0 | 4798.08 | CHUDAKOV | 1 | 1 | D | H | EUGENE C | 11-006 | 11-026 |  |  |  |  |  |  | 12-021 |  |  |  |
| 1546300 |  | BCAL Readout Procurement Support | 127d | 2012-05-01 A | 2012-10-29 A | 9-120M FS+164d | 100% |  |  | ELEC ENG [272 h] | 19,293.52 | 19,293.52 | 0 | 19192.32 | CHUDAKOV | 1 | 1 | D | H | EUGENE C | 11-006 | 11-026 |  |  |  |  |  |  | 12-021 |  |  |  |
| 1546310 |  | Procure U-Boards (Qty.3840) | 73d | 2012-05-01 A | 2012-08-13 A | 1546305 FS-120d | 100% |  |  | PROCUREMENT>$50K 69; PROCUREMENT<$50K 60 | 100,680 |  | 0 | 100680 | CHUDAKOV | 1 | 1 | D | D | EUGENE C | 11-006 | 11-026 |  | 0 | 100680 | 10068000 | 100 |  | 12-021 |  |  |  |
| 1546510 |  | Start Counter Prototype Parts,Fab and Assembly | 28d | 2012-05-01 A | 2012-06-11 A | 1546505 FS-10d | 100% |  |  | PROCUREMENT<$50K 60; ELEC TECH [68 h] | 8,000.84 | 3,000.84 | 0 | 8000.84 | CHUDAKOV | 1 | 1 | D | H | EUGENE C | 11-006 | 11-026 |  | 0 | 5000 | 500000 | 100 |  | 12-021 |  |  |  |
| 1546315 |  | Procure Thermistor Boards (Qty.384) | 16d | 2012-07-02 A | 2012-07-23 A | 1546310 FS-28d | 100% |  |  | PROCUREMENT<$50K 60 | 19,706 |  | 0 | 19706 | CHUDAKOV | 1 | 1 | D | D | EUGENE C | 11-006 | 11-026 |  | 0 | 19706 | 1970600 | 100 |  | 12-021 |  |  |  |
| 1546320 |  | Procure Transition Boards (Qty.96) | 55d | 2012-07-02 A | 2012-09-17 A | 1546315 FS-18d | 100% |  |  | PROCUREMENT<$50K 60 | 45,032 |  | 0 | 45032 | CHUDAKOV | 1 | 1 | D | D | EUGENE C | 11-006 | 11-026 |  | 0 | 45032 | 4503200 | 100 |  | 12-021 |  |  |  |
| 1546325 |  | Procure Power Distribution (Qty.18) | 140d | 2012-07-02 A | 2013-08-23 A | 1546320 FS-40d | 100% | 2012-07-02 | 2013-01-25 | PROCUREMENT<$50K 60 | 11,700 |  | 2340 | 11700 | CHUDAKOV | 1 | 1 | D | D | EUGENE C | 11-006 | 11-026 |  | 0 | 11700 | 1170000 | 100 |  | 12-021 | XX |  |  |
| 1546450 |  | Procure LV Mod Preamp | 55d | 2012-07-02 A | 2012-09-17 A | 1546445 FS-20d | 100% |  |  | PROCUREMENT<$50K 60 | 7,223.3 |  | 0 | 7223.3 | CHUDAKOV | 1 | 1 | D | D | EUGENE C | 11-006 | 11-026 |  | 0 | 7223.3 | 722330 | 100 |  | 12-021 |  |  |  |
| 1546455 |  | Procure LV Bias | 55d | 2012-07-02 A | 2012-09-17 A | 1546445 FS-20d | 100% |  |  | PROCUREMENT<$50K 60 | 9,287.1 |  | 0 | 9287.1 | CHUDAKOV | 1 | 1 | D | D | EUGENE C | 11-006 | 11-026 |  | 0 | 9287.1 | 928710 | 100 |  | 12-021 |  |  |  |
| 1546460 |  | Procure LV Chassis | 55d | 2012-07-02 A | 2012-09-17 A | 1546445 FS-20d | 100% |  |  | PROCUREMENT<$50K 60 | 6,810.54 |  | 0 | 6810.54 | CHUDAKOV | 1 | 1 | D | D | EUGENE C | 11-006 | 11-026 |  | 0 | 6810.54 | 681054 | 100 |  | 12-021 |  |  |  |
| 1546515 |  | Test Start Counter Prototype | 11d | 2012-07-02 A | 2012-07-16 A | 1546510 | 100% |  |  | ELEC ENG [28 h]; ELEC TECH [68 h] | 4,976.52 | 4,976.52 | 0 | 4976.52 | CHUDAKOV | 1 | 1 | D | H | EUGENE C | 11-006 | 11-026 |  |  |  |  |  |  | 12-021 |  |  |  |
| 1546550 |  | Procure LV Mod Preamp | 55d | 2012-07-02 A | 2012-09-17 A | 9-130M FS-60d | 100% |  |  | PROCUREMENT<$50K 60 | 7,223.3 |  | 0 | 7223.3 | CHUDAKOV | 1 | 1 | D | D | EUGENE C | 11-006 | 11-026 |  | 0 | 7223.3 | 722330 | 100 |  | 12-021 |  |  |  |
| 1546555 |  | Procure LV Bias | 55d | 2012-07-02 A | 2012-09-17 A | 9-130M FS-60d | 100% |  |  | PROCUREMENT<$50K 60 | 9,287.1 |  | 0 | 9287.1 | CHUDAKOV | 1 | 1 | D | D | EUGENE C | 11-006 | 11-026 |  | 0 | 9287.1 | 928710 | 100 |  | 12-021 |  |  |  |
| 1546560 |  | Procure LV Chassis | 54d | 2012-07-02 A | 2012-09-17 A | 9-130M FS-60d | 100% | 2012-07-02 | 2012-09-14 | PROCUREMENT<$50K 60 | 6,810.54 |  | 0 | 6810.54 | CHUDAKOV | 1 | 1 | D | D | EUGENE C | 11-006 | 11-026 |  | 0 | 6810.54 | 681054 | 100 |  | 12-021 |  |  |  |
| 1546365 |  | Test U-Boards FY12 | 24.5d | 2012-08-13 A | 2012-09-17 A | 1546310, 1546360 FS-115d | 100% |  |  | ELEC TECH [505.6 h] | 22,312.13 | 22,312.13 | 0 | 22312.128 | CHUDAKOV | 1 | 1 | D | U | EUGENE C | 11-006 | 11-026 |  |  |  |  |  |  | 12-021 |  | Aug 12 | 12-053 |
| 1546365a |  | Test U-Boards FY13 | 25d | 2012-08-13 A | 2012-09-17 A | 1546365 FS-160d | 100% |  |  | ELEC TECH [38.4 h] | 1,694.59 | 1,694.59 | 0 | 1748.736 | CHUDAKOV | 1 | 1 | D | U | EUGENE C | 11-006 | 11-026 |  |  |  |  |  |  | 12-021 |  |  | 12-053 |
| 1546370 |  | Test Thermistor Boards | 154d | 2012-08-13 A | 2013-02-11 A | 1546315, 1546365a FS-160d | 100% | 2012-08-13 | 2013-03-29 | ELEC TECH [272 h] | 12,302.21 | 12,279.11 | 0 | 12003.36 | CHUDAKOV | 1 | 1 | D | U | EUGENE C | 11-006 | 11-026 |  |  |  |  |  |  | 12-021 |  | Aug 12 |  |
| 1546375 |  | Test Transition Boards | 121d | 2012-08-13 A | 2013-02-11 A | 1546370 FS-165d, 1546320 FS-20d | 100% |  |  | ELEC TECH [68 h] | 3,069.78 | 3,069.78 | 0 | 3000.84 | CHUDAKOV | 1 | 1 | D | U | EUGENE C | 11-006 | 11-026 |  |  |  |  |  |  | 12-021 | XX | Aug 12 |  |
| 1546305 |  | Procure BCAL Readout V3 (Qty.96) $$ Reside @ 15221160ab per CR12-021 | 97d | 2012-09-03 A | 2012-12-17 A | 1546300 FS-123d, 15221161n FS-205d, 15221161j FS-205d, 15221161k FS-205d, 15221161s FS-205d, 15221161f FS-205d, 15221161a FS-205d, 15221161b FS-205d, 15221161c FS-205d, 15221161h FS-205d | 100% | 2012-09-04 | 2013-01-29 |  |  |  |  | 0 | CHUDAKOV | 1 | 1 | D | Z | EUGENE C | 11-006 | 11-026 |  |  |  |  |  |  | 12-021 |  |  |  |
| 1546440 |  | Procure Pair Spectrometer Coax Cables | 30d | 2012-09-03 A | 2012-10-15 A | 1546420 FS-60d | 100% | 2012-09-04 | 2012-10-15 | PROCUREMENT<$50K 60 NO ESCALATION FY13 | 10,500 |  | 0 | 10500 | CHUDAKOV | 1 | 1 | D | D | EUGENE C | 11-006 | 11-026 |  | 0 | 10500 | 1050000 | 100 |  | 12-021 |  |  |  |
| 1546465 |  | Procure LV Cables | 103d | 2012-09-03 A | 2013-08-30 A | 1546445 | 100% | 2012-09-04 | 2013-02-06 | PROCUREMENT<$50K 60 | 412.76 |  | 82.552 | 412.76 | CHUDAKOV | 1 | 1 | D | D | EUGENE C | 11-006 | 11-026 |  | 0 | 412.76 | 41276 | 100 |  | 12-021 | XX |  |  |
| 1546540 |  | Procure Start Counter Coax Cables | 10d | 2012-09-03 A | 2012-09-17 A | 1546520 FS-5d | 100% | 2012-09-04 | 2012-09-17 | PROCUREMENT<$50K 60 | 1,599.45 |  | 0 | 1599.45 | CHUDAKOV | 1 | 1 | D | D | EUGENE C | 11-006 | 11-026 |  | 0 | 1599.45 | 159945 | 100 |  | 12-021 |  |  |  |

| ID | Activity | Duration | Start | Finish | Predecessors | Complete | Remaining | Planned start | Planned finish | Total float | Free float | Calendar | Resources | Cost | Actual cost | Remaining Material Cost Based on % Compl | Claimed Material Cost Based on % Complet | Initial Claimed Material Calc | Claimed Material Divider | Calculated Remaining Total Cost | MONTHLY EV COST | RESP - Responsibility | STRT%COMP for CM EVM | FNSH%COMP for CM EVM | HALL D Related Milestones | EVMS Reporting Codes | CAM RESPONSIBLE | CR 11-006 | CR 11-026 | CR 12-021 | MARCH!!! | CR 12-053 | CR 12-054 | ReBaseline Actuals Adjustment | Original Activity ID Rebaseline | PRIOR MONTH EV COST | CR 13-007 | BOE Labor | CR 13-015 | Post Rebaseline | BOE Procurement | Obligated Prior to Rebaseline | BOE Expenses | CR 14-001 | Activities with Steps |
| --- | --- | --- | --- | --- | --- | --- | --- | --- | --- | --- | --- | --- | --- | --- | --- | --- | --- | --- | --- | --- | --- | --- | --- | --- | --- | --- | --- | --- | --- | --- | --- | --- | --- | --- | --- | --- | --- | --- | --- | --- | --- | --- | --- | --- | --- |
| 1546330 | Procure Coax Cables (Qty.768) | 11d | 2012-10-01 A | 2012-10-15 A | 1546325 FS-40d | 100% |  |  |  |  |  |  | PROCUREMENT<$50K 60 | 38,400 |  | 0 | 38400 | 3840000 | 100 | 0 | 38400 | CHUDAKOV | 1 | 1 | D | D | EUGENE C | 11-006 | 11-026 | 12-021 |  |  |  |  |  |  |  |  |  |  |  |  |  |  |  |
| 1546360 | Test BCAL Readout V3 | 51d | 2013-01-07 A | 2013-03-11 A | 1546305 FS-15d | 100% |  | 2013-02-01 | 2013-04-15 |  |  |  | ELEC ENG [68 h]; ELEC TECH [272 h] | 17,337.96 | 17,337.96 |  |  |  |  | 0 | 16801.44 | CHUDAKOV | 1 | 1 | D | H | EUGENE C | 11-006 | 11-026 | 12-021 |  |  |  |  |  |  |  |  |  |  |  |  |  |  |  |
| 1546345 | Procure Disc/TDC Cable(Qty.24) | 24d | 2013-03-01 A | 2013-03-18 A | 9-130M FS+110d | 100% |  | 2013-04-01 | 2013-05-02 |  |  |  | PROCUREMENT<$50K 60 | 619.14 |  | 0 | 619.14 | 61914 | 100 | 0 | 619.14 | CHUDAKOV | 1 | 1 | D | D | EUGENE C | 11-006 | 11-026 | 12-021 | XX |  |  |  |  |  |  |  |  |  |  |  |  |  |  |
| 1546520 | Start Counter Production Procurement Prep | 39d | 2013-03-04 A | 2013-05-13 A | 9-130M FS+110d, 1546515 | 100% |  | 2013-04-01 | 2013-05-23 |  |  |  | ELEC ENG [96 h] | 6,989.76 | 6,989.76 |  |  |  |  | 0 | 6989.76 | CHUDAKOV | 1 | 1 | D | H | EUGENE C | 11-006 | 11-026 | 12-021 |  |  |  |  |  |  |  |  |  |  |  |  |  |  |  |
| 1546380 | Test Power Distribution FY12 | 19d | 2013-04-15 A | 2013-08-30 A | 1546325 FS-20d, 1546375, 1546390 FS-20d | 100% |  | 2013-05-24 | 2013-06-20 |  |  |  | ELEC ENG [62.9 h] | 4,579.75 | 4,579.75 |  |  |  |  | 2219.112 | 4438.224 | CHUDAKOV | 1 | 1 | D | H | EUGENE C | 11-006 | 11-026 | 12-021 |  | 12-053 |  |  |  |  |  |  |  |  |  |  |  |  |  |
| 1546525 | Procure Start Counter ST Readout Board | 49d | 2013-05-02 A | 2013-06-17 A | 1546520 FS-15d | 100% |  | 2013-06-12 | 2013-08-20 |  |  |  | PROCUREMENT<$50K 60 | 5,159.5 |  | 0 | 5159.5 | 515950 | 100 | 0 | 5159.5 | CHUDAKOV | 1 | 1 | D | D | EUGENE C | 11-006 | 11-026 | 12-021 |  |  |  |  |  |  |  |  |  |  |  |  |  |  |  |
| 1546565 | Procure LV Cables | 91d | 2013-05-06 A | 2013-08-30 A | 9-130M | 100% |  | 2013-06-25 | 2013-10-31 |  |  |  | PROCUREMENT<$50K 60 | 412.76 |  | 0 | 412.76 | 41276 | 100 | 82.552 | 412.76 | CHUDAKOV | 1 | 1 | D | D | EUGENE C | 11-006 | 11-026 | 12-021 |  |  |  |  |  |  |  |  |  |  |  |  |  |  |  |
| 1546530 | Procure Start Counter Transition Board | 17d | 2013-05-13 A | 2013-06-17 A | 1546520 FS-5d | 100% |  | 2013-06-03 | 2013-06-25 |  |  |  | PROCUREMENT<$50K 60 | 1,651.04 |  | 0 | 1651.04 | 165104 | 100 | 0 | 1651.04 | CHUDAKOV | 1 | 1 | D | D | EUGENE C | 11-006 | 11-026 | 12-021 |  |  |  |  |  |  |  |  |  |  |  |  |  |  |  |
| 1546535 | Procure Start Counter Power Distribution | 39d | 2013-05-13 A | 2013-06-17 A | 1546520 FS-5d | 100% |  | 2013-06-03 | 2013-07-26 |  |  |  | PROCUREMENT<$50K 60 | 1,083.5 |  | 0 | 1083.5 | 108350 | 100 | 0 | 1083.5 | CHUDAKOV | 1 | 1 | D | D | EUGENE C | 11-006 | 11-026 | 12-021 |  |  |  |  |  |  |  |  |  |  |  |  |  |  |  |
| 1546405 | Pair Spectrometer Prototype Procurement Prep | 11d | 2013-07-08 A | 2013-08-15 A | 1546400 | 100% |  | 2013-08-26 | 2013-09-10 |  |  |  | ELEC ENG [96 h] | 6,989.76 | 6,989.76 |  |  |  |  | 6773.76 | 6773.76 | CHUDAKOV | 1 | 1 | D | H | EUGENE C | 11-006 | 11-026 | 12-021 | XX |  | 12-054F |  |  |  |  |  |  |  |  |  |  |  |  |
| 1546410 | Pair Spectrometer Prototype Parts,Fab and Assembly | 39d | 2013-07-15 A | 2013-08-26 A | 1546405 FS-30d | 100% |  | 2013-08-27 | 2013-10-21 |  |  |  | ELEC TECH [68 h]; PROCUREMENT<$50K 60 | 8,134.64 | 3,096.72 | 0 | 5000 | 500000 | 100 | 8000.84 | 8000.84 | CHUDAKOV | 1 | 1 | D | H | EUGENE C | 11-006 | 11-026 | 12-021 |  |  | 12-054F |  |  |  |  |  |  |  |  |  |  |  |  |
| 1546415 | Test Pair Spectrometer Prototype | 32d | 2013-08-01 A | 2013-08-26 A | 1546410 | 100% |  | 2013-09-26 | 2013-11-08 |  |  |  | ELEC ENG [68 h]; ELEC TECH [68 h] | 8,280.13 | 8,047.8 |  |  |  |  | 7798.92 | 7798.92 | CHUDAKOV | 1 | 1 | D | H | EUGENE C | 11-006 | 11-026 | 12-021 |  |  | 12-054F |  |  |  |  |  |  |  |  |  |  |  |  |
| 1546420 | Pair Spectrometer Production Procurement Prep | 15d | 2013-08-01 A | 2013-08-21 A | 1546415 FS-75d | 100% |  |  |  |  |  |  | ELEC ENG [28 h]; ELEC TECH [68 h] | 5,135.4 | 5,135.4 |  |  |  |  | 4976.52 | 4976.52 | CHUDAKOV | 1 | 1 | D | H | EUGENE C | 11-006 | 11-026 | 12-021 | XX |  | 12-054F |  |  |  |  |  |  |  |  |  |  |  |  |
| 1546425 | Procure Pair Spectrometer Readout Board | 39d | 2013-08-07 A | 2013-08-30 A | 1546420 FS-11d | 100% |  | 2013-08-07 | 2013-10-01 |  |  |  | PROCUREMENT<$50K 60 | 5,800 |  | 0 | 5800 | 580000 | 100 | 5800 | 5800 | CHUDAKOV | 1 | 1 | D | D | EUGENE C | 11-006 | 11-026 | 12-021 |  |  |  |  |  |  |  |  |  |  |  |  |  |  |  |
| 1546430 | Procure Pair Spectrometer Transition Board | 39d | 2013-08-07 A | 2013-08-30 A | 1546420 FS-11d | 100% |  | 2013-08-07 | 2013-10-01 |  |  |  | PROCUREMENT<$50K 60 | 1,600 |  | 0 | 1600 | 160000 | 100 | 1600 | 1600 | CHUDAKOV | 1 | 1 | D | D | EUGENE C | 11-006 | 11-026 | 12-021 |  |  | 12-054F |  |  |  |  |  |  |  |  |  |  |  |  |
| 1546435 | Procure Pair Spectrometer Power Distribution | 39d | 2013-08-07 A | 2013-08-30 A | 1546420 FS-11d | 100% |  | 2013-08-07 | 2013-10-01 |  |  |  | PROCUREMENT<$50K 60 | 1,050 |  | 0 | 1050 | 105000 | 100 | 1050 | 1050 | CHUDAKOV | 1 | 1 | D | D | EUGENE C | 11-006 | 11-026 | 12-021 |  |  | 12-054F |  |  |  |  |  |  |  |  |  |  |  |  |
| 1546570 | Re-Baseline Actuals Adjustment | 1d | 2013-08-30 A | 2013-08-30 A |  | 100% |  | 2013-09-03 | 2013-09-03 |  |  |  | PROCUREMENT>$50K 69 NO ESCALATION | -130,660.48 |  |  |  |  | 100 |  |  |  |  |  |  |  |  |  |  |  |  |  |  | ADJ |  |  |  |  |  |  |  |  |  |  |  |
| 2546362 | Assemble BCAL Readout V3, Power Dist. & SYST | 20d | 2013-09-03 A | 2013-12-02 | 9-130M FS+228d | 50% | 20d | 2013-10-01 | 2013-10-28 | 151d | 0d | 8/5 M-F w/JLAB Holidays ReBaseline | ELEC TECH [48 h]; ELEC ENG [8 h] | 2,856.56 | 1,384.2 |  |  |  |  |  | 1107.36 | CHUDAKOV | 1 | 1 | D | U | EUGENE C |  |  |  |  |  |  |  | 2546362 | 276.84 | 13-007 | EJ | 13-015 | PR |  |  |  |  |  |
| 2546425 | Procure Pair Spectrometer Readout Board | 20d | 2013-09-03 A | 2013-10-21 A | 9-130M FS+228d | 100% |  | 2013-10-01 | 2013-10-28 |  |  | 8/5 M-F w/JLAB Holidays ReBaseline | PROCUREMENT<$50K 60 | 3,747.65 |  | 0 | 3747.65 | 374765 | 100 |  | 3747.65 | CHUDAKOV | 1 | 1 | D | D | EUGENE C | 11-006 | 11-026 | 12-021 |  |  |  |  | 2546425 |  |  |  | 13-015 | PR | PE | OB |  |  |  |
| 2546430 | Procure Pair Spectrometer Transition Board | 20d | 2013-09-03 A | 2013-09-23 A | 9-130M FS+228d | 100% |  | 2013-10-01 | 2013-10-28 |  |  | 8/5 M-F w/JLAB Holidays ReBaseline | PROCUREMENT<$50K 60 | 3,226 |  | 0 | 3226 | 322600 | 100 |  | 0 | CHUDAKOV | 1 | 1 | D | D | EUGENE C | 11-006 | 11-026 | 12-021 |  |  | 12-054F |  | 2546430 | 3226 |  |  | 13-015 | PR | PE | OB |  |  |  |
| 2546435 | Procure Pair Spectrometer Power Distribution | 20d | 2013-09-03 A | 2013-09-23 A | 9-130M FS+228d | 100% |  | 2013-10-01 | 2013-10-28 |  |  | 8/5 M-F w/JLAB Holidays ReBaseline | PROCUREMENT<$50K 60 | 3,220 |  | 0 | 3220 | 322000 | 100 |  | 0 | CHUDAKOV | 1 | 1 | D | D | EUGENE C | 11-006 | 11-026 | 12-021 |  |  | 12-054F |  | 2546435 | 3220 |  |  | 13-015 | PR | PE | OB |  |  |  |
| 2546465 | Procure LV Cables | 20d | 2013-09-03 A | 2013-12-02 | 9-130M FS+228d | 70% | 20d | 2013-10-01 | 2013-10-28 | 204d |  | 8/5 M-F w/JLAB Holidays ReBaseline | ELEC TECH [8 h]; PROCUREMENT<$50K 60 | 455.92 | 182.16 | 24 | 56 | 5600 | 100 |  | 88.864 | CHUDAKOV | 1 | 1 | D | D | EUGENE C | 11-006 | 11-026 | 12-021 |  |  |  |  | 2546465 | 222.16 |  | PE | 13-015 | PR | PE | OB-2 |  |  |  |
| 2546565 | Procure LV Cables | 20d | 2013-09-03 A | 2013-12-02 | 9-130M FS+228d | 30% | 20d | 2013-10-01 | 2013-10-28 | 204d |  | 8/5 M-F w/JLAB Holidays ReBaseline | ELEC TECH [4 h]; PROCUREMENT<$50K 60 | 229.24 | 91.08 | 28.896 | 12.384 | 1238.4 | 100 |  | 22.344 | CHUDAKOV | 1 | 1 | D | D | EUGENE C | 11-006 | 11-026 | 12-021 |  |  |  |  | 2546565 | 44.688 |  | PE | 13-015 | PR | PE | OB-2 |  |  |  |
| 2546600 | Tagger Hodoscope PreAmp Board (233) (Previously Obligated) | 49d | 2013-09-03 A | 2013-12-20 | 9-130M FS+228d | 80% | 34d | 2013-10-01 | 2013-12-10 | 130d | 63d | 8/5 M-F w/JLAB Holidays ReBaseline | PROCUREMENT<$50K 60 NO ESCALATION FY14 | 12,865 |  | 2573 | 10292 | 1029200 | 100 |  | 3859.5 | CHUDAKOV | 1 | 1 | D | D | EUGENE C |  |  |  |  |  |  |  | 2546600 | 6432.5 | 13-007 | PE | 13-015 | PR | PE | OB |  |  |  |
| 2546615 | BCAL/FCAL Monitoring Distribution COTS Electronics | 77d | 2013-09-03 A | 2014-02-04 | 9-130M FS+228d |  | 57d | 2013-10-01 | 2014-01-30 | 167d |  | 8/5 M-F w/JLAB Holidays ReBaseline | PROCUREMENT<$50K 60 NO ESCALATION FY14 | 16,134 |  | 16134 | 0 | 0 | 100 |  | 0 | CHUDAKOV | 1 | 1 | D | D | EUGENE C |  |  |  |  |  |  |  | 2546615 |  | 13-007 |  | 13-015 | PR | CP | OB |  |  |  |
| 2546625 | BCAL/FCAL Monitoring Distribution Cables (64+64) (Previously Obligated) | 98d | 2013-09-03 A | 2013-10-21 A | 9-130M FS+228d | 100% |  | 2013-10-01 | 2014-02-28 |  |  | 8/5 M-F w/JLAB Holidays ReBaseline | PROCUREMENT<$50K 60 NO ESCALATION FY14 | 6,012 |  | 0 | 6012 | 601200 | 100 |  | 6012 | CHUDAKOV | 1 | 1 | D | D | EUGENE C |  |  |  |  |  |  |  | 2546625 |  | 13-007 |  | 13-015 | PR | PE | OB |  |  |  |
| 2546630 | BCAL/FCAL Monitoring Distribution Cables (64+64) | 98d | 2013-09-03 A | 2014-01-31 | 9-130M FS+228d | 20% | 55d | 2013-10-01 | 2014-02-28 | 169d |  | 8/5 M-F w/JLAB Holidays ReBaseline | PROCUREMENT<$50K 60 NO ESCALATION FY14 | 3,588 |  | 2870.4 | 717.6 | 71760 | 100 |  | 717.6 | CHUDAKOV | 1 | 1 | D | D | EUGENE C |  |  |  |  |  |  |  | 2546625 |  | 13-007 |  | 13-015 | PR | PE | OB-2 |  |  |  |
| 2546640 | Cables Type 1 (TAGH PS PSC COLLI) (350) | 77d | 2013-09-03 A | 2013-10-21 A | 9-130M FS+228d | 100% |  | 2013-10-01 | 2014-01-30 |  |  | 8/5 M-F w/JLAB Holidays ReBaseline | PROCUREMENT<$50K 60 NO ESCALATION FY14 | 18,484 |  | 0 | 18484 | 1848400 | 100 |  | 14787.2 | CHUDAKOV | 1 | 1 | D | D | EUGENE C |  |  |  |  |  |  |  | 2546640 | 3696.8 | 13-007 |  | 13-015 | PR | PE | OB |  |  |  |
| 2546645 | Splitter Output (TOF TAGM PSC) (630) | 54d | 2013-09-03 A | 2013-10-21 A | 9-130M FS+228d | 100% |  | 2013-10-01 | 2013-12-17 |  |  | 8/5 M-F w/JLAB Holidays ReBaseline | PROCUREMENT<$50K 60 NO ESCALATION FY14 | 31,331 |  | 0 | 31331 | 3133100 | 100 |  | 28197.9 | CHUDAKOV | 1 | 1 | D | D | EUGENE C |  |  |  |  |  |  |  | 2546645 | 3133.1 | 13-007 |  | 13-015 | PR | PE | OB |  |  |  |
| 2546650 | Install Hardware, Labels and Tie Wraps FY13 | 20d | 2013-09-03 A | 2014-09-30 | 9-130M FS+228d | 16% | 224d | 2013-10-01 | 2013-10-28 | 0d |  | 8/5 M-F w/JLAB Holidays ReBaseline | SUPPLIES & MATERIALS | 449.44 |  |  |  |  |  |  | 26.9664 | CHUDAKOV | 1 | 1 | D | D | EUGENE C |  |  |  |  |  |  |  | 2546650 | 44.944 | 13-007 |  | 13-015 | PR |  |  | EJ |  |  |
| 2546650a | Install Hardware, Labels and Tie Wraps FY14 | 247d | 2013-09-03 A | 2014-09-30 | 2546650 FS-247d | 16% | 224d | 2013-10-01 | 2014-09-30 | 0d |  | 8/5 M-F w/JLAB Holidays ReBaseline | SUPPLIES & MATERIALS | 5,727.62 |  |  |  |  |  |  | 343.6572 | CHUDAKOV | 1 | 1 | D | D | EUGENE C |  |  |  |  |  |  |  | 2546650 | 572.762 | 13-007 |  | 13-015 | PR |  |  | EJ | 14-001 |  |
| 2546660 | Twisted Pair Cables for TDCs | 77d | 2013-09-03 A | 2013-12-20 | 9-130M FS+228d | 10% | 34d | 2013-10-01 | 2014-01-30 | 100d | 0d | 8/5 M-F w/JLAB Holidays ReBaseline | PROCUREMENT<$50K 60 NO ESCALATION FY14 | 1,908 |  | 1717.2 | 190.8 | 19080 | 100 |  | 190.8 | CHUDAKOV | 1 | 1 | D | D | EUGENE C |  |  |  |  |  |  |  | 2546660 |  | 13-007 |  | 13-015 | PR | CP | OB |  |  |  |
| 2546470 | Pair Spectrometer Integration FY13 | 16d | 2013-10-01 A | 2013-12-20 | 9-130M FS+232d | 55% | 34d | 2013-11-01 | 2013-11-22 | 175d | 6d | 8/5 M-F w/JLAB Holidays ReBaseline | ELEC TECH [52.6 h] | 2,471.67 | 997.34 |  |  |  |  |  | 1317.4722 | CHUDAKOV | 1 | 1 | D | U | EUGENE C | 11-006 | 11-026 | 12-021 |  |  |  |  | 2546470 |  |  | EJ | 13-015 | PR |  |  |  |  |  |
| 2546470a | Pair Spectrometer Integration FY14 | 57d | 2013-10-01 A | 2013-12-20 | 2546470 FS-40d | 55% | 34d | 2013-11-25 | 2014-02-26 | 175d | 64d | 8/5 M-F w/JLAB Holidays ReBaseline | ELEC TECH [187.4 h] | 8,805.93 | 3,553.27 |  |  |  |  |  | 4843.2593 | CHUDAKOV | 1 | 1 | D | U | EUGENE C | 11-006 | 11-026 | 12-021 |  |  |  |  | 2546470 |  |  | EJ | 13-015 | PR |  |  |  | 14-001 |  |
| 2546567 | Start Counter Integration FY13 | 20d | 2013-10-01 A | 2013-12-10 | 9-130M FS+228d | 55% | 26d | 2013-11-01 | 2013-12-02 | 188d | 4d | 8/5 M-F w/JLAB Holidays ReBaseline | ELEC TECH [29.39 h] | 1,381.04 | 648.24 |  |  |  |  |  | 736.13133 | CHUDAKOV | 1 | 1 | D | U | EUGENE C | 11-006 | 11-026 | 12-021 |  |  |  |  | 2546567 |  |  | PE | 13-015 | PR |  |  |  |  |  |
| 2546567a | Start Counter Integration FY14 | 29d | 2013-10-01 A | 2013-12-10 | 2546567 FS-30d | 55% | 26d | 2013-12-03 | 2014-01-23 | 188d |  | 8/5 M-F w/JLAB Holidays ReBaseline | ELEC TECH [42.61 h] | 2,002.24 | 939.83 |  |  |  |  |  | 1101.234145 | CHUDAKOV | 1 | 1 | D | U | EUGENE C | 11-006 | 11-026 | 12-021 |  |  |  |  | 2546567 |  |  | PE | 13-015 | PR |  |  |  | 14-001 |  |
| 2546585 | Tagger Microscope PreAmp Board (37) Procurement $ now Labor | 82d | 2013-10-01 A | 2013-10-21 A | 9-130M FS+228d, 9-140M | 100% |  | 2013-11-01 | 2014-03-11 |  |  | 8/5 M-F w/JLAB Holidays ReBaseline | ELEC TECH; PROCUREMENT<$50K 60 NO ESCALATION FY14 | 7,500 |  | 0 | 7500 | 750000 | 100 |  | 7500 | CHUDAKOV | 1 | 1 | D | U | EUGENE C |  |  |  |  |  |  |  | 2546585 |  | 13-007 | PE | 13-015 | PR | PE | OB-2 |  |  |  |
| 2546585a | Tagger Microscope PreAmp Board (37) Labor FY13 | 20d | 2013-10-01 A | 2013-12-17 | 9-140M | 2% | 31d | 2013-11-01 | 2013-12-02 | 139d | 9d | 8/5 M-F w/JLAB Holidays ReBaseline | ELEC TECH [44.44 h] | 2,088.24 | 889.43 |  |  |  |  |  | 40.475952 | CHUDAKOV | 1 | 1 | D | U | EUGENE C |  |  |  |  |  |  |  | 2546585 |  | 13-007 | PE | 13-015 | PR | PE |  |  |  |  |
| 2546585b | Tagger Microscope PreAmp Board (37) Labor FY14 | 34d | 2013-10-01 A | 2013-12-20 | 2546585a FS-40d | 2% | 34d | 2013-12-03 | 2014-01-30 | 130d | 63d | 8/5 M-F w/JLAB Holidays ReBaseline | ELEC TECH [75.56 h] | 3,550.56 | 1,432.68 |  |  |  |  |  | 71.011288 | CHUDAKOV | 1 | 1 | D | U | EUGENE C |  |  |  |  |  |  |  | 2546585 |  | 13-007 | PE | 13-015 | PR | PE |  |  | 14-001 |  |
| 2546605 | Tagger Hodoscope PreAmp Board (233) Procurement $ now Labor | 57d | 2013-10-01 A | 2013-10-21 A | 9-130M FS+228d | 100% |  | 2013-11-01 | 2014-02-04 |  |  | 8/5 M-F w/JLAB Holidays ReBaseline | PROCUREMENT<$50K 60 NO ESCALATION FY14; ELEC ENG; ELEC TECH | 3,134.92 |  | 0 | 3134.92 | 313492 | 100 |  | 3134.92 | CHUDAKOV | 1 | 1 | D | D | EUGENE C |  |  |  |  |  |  |  | 2546600 |  | 13-007 | PE | 13-015 | PR | PE | OB-2 |  |  |  |
| 2546605a | Tagger Hodoscope PreAmp Board (233) - Labor FY13 | 20d | 2013-10-01 A | 2013-12-10 | 9-130M FS+228d | 30% | 26d | 2013-11-01 | 2013-12-02 | 139d | 4d | 8/5 M-F w/JLAB Holidays ReBaseline | ELEC ENG [6.53 h]; ELEC TECH [52.25 h] | 2,945.86 | 1,382.75 |  |  |  |  |  | 856.4833791 | CHUDAKOV | 1 | 1 | D | U | EUGENE C |  |  |  |  |  |  |  | 2546600 |  | 13-007 | PE | 13-015 | PR | PE |  |  |  |  |
| 2546605b | Tagger Hodoscope PreAmp Board (233) - Labor FY14 | 29d | 2013-10-01 A | 2013-12-13 | 2546605a FS-30d | 30% | 29d | 2013-12-03 | 2014-01-23 | 135d | 68d | 8/5 M-F w/JLAB Holidays ReBaseline | ELEC ENG [9.47 h]; ELEC TECH [75.75 h] | 4,270.94 | 1,889.07 |  |  |  |  |  | 1281.2827011 | CHUDAKOV | 1 | 1 | D | U | EUGENE C |  |  |  |  |  |  |  | 2546600 |  | 13-007 | PE | 13-015 | PR | PE |  |  | 14-001 |  |
| 2546610 | BCAL/FCAL Monitoring Distribution Sys. Procurement Support FY13 | 20d | 2013-10-01 A | 2014-01-28 | 9-130M FS+228d | 60% | 52d | 2013-11-01 | 2013-12-02 | 172d | 8d | 8/5 M-F w/JLAB Holidays ReBaseline | ELEC ENG [7.58 h]; ELEC TECH [30.31 h] | 1,993.7 | 611.4 |  |  |  |  |  | 1159.297596 | CHUDAKOV | 1 | 1 | D | S | EUGENE C |  |  |  |  |  |  |  | 2546610 |  | 13-007 | PE | 13-015 | PR |  |  |  |  | ST |
| 2546610a | BCAL/FCAL Monitoring Distribution Sys. Procurement Support FY14 | 75d | 2013-10-01 A | 2014-01-28 | 2546610 FS-60d | 60% | 52d | 2013-12-03 | 2014-03-28 | 172d |  | 8/5 M-F w/JLAB Holidays ReBaseline | ELEC ENG [28.42 h]; ELEC TECH [113.69 h] | 7,477.54 | 2,293.11 |  |  |  |  |  | 4486.526388 | CHUDAKOV | 1 | 1 | D | S | EUGENE C |  |  |  |  |  |  |  | 2546610 |  | 13-007 | PE | 13-015 | PR |  |  |  | 14-001 | ST |
| 2546620 | BCAL/FCAL Monitoring Distribution Box (10) Procurement | 95d | 2013-10-01 A | 2014-01-28 | 9-130M FS+228d |  | 52d | 2013-11-01 | 2014-03-28 | 172d |  | 8/5 M-F w/JLAB Holidays ReBaseline | ELEC TECH; PROCUREMENT<$50K 60 NO ESCALATION FY14 | 10,000 |  | 10000 | 0 | 0 | 100 |  | 0 | CHUDAKOV | 1 | 1 | D | S | EUGENE C |  |  |  |  |  |  |  | 2546620 |  | 13-007 | PE | 13-015 | PR | PE | OB-2 |  |  |  |
| 2546620a | BCAL/FCAL Monitoring Distribution Box (10) - Labor FY13 | 20d | 2013-10-01 A | 2014-01-28 | 9-130M FS+228d |  | 52d | 2013-11-01 | 2013-12-02 | 180d | 8d | 8/5 M-F w/JLAB Holidays ReBaseline | ELEC TECH [42.11 h] | 1,978.75 | 606.82 |  |  |  |  |  | 0 | CHUDAKOV | 1 | 1 | D | S | EUGENE C |  |  |  |  |  |  |  | 2546620 |  | 13-007 | PE | 13-015 | PR | PE |  |  |  |  |
| 2546620b | BCAL/FCAL Monitoring Distribution Box (10) - Labor FY4 | 75d | 2013-10-01 A | 2014-01-28 | 2546620a FS-60d |  | 52d | 2013-12-03 | 2014-03-28 | 172d |  | 8/5 M-F w/JLAB Holidays ReBaseline | ELEC TECH [157.89 h] | 7,419.25 | 2,275.24 |  |  |  |  |  | 0 | CHUDAKOV | 1 | 1 | D | S | EUGENE C |  |  |  |  |  |  |  | 2546620 |  | 13-007 | PE | 13-015 | PR | PE |  |  | 14-001 |  |
| 2546655 | Splitters Parts Boards and Assembly (10) | 139d | 2013-11-08 | 2014-06-06 | 9-140M FS+28d |  |  |  |  | 80d |  | 8/5 M-F w/JLAB Holidays ReBaseline | ELEC TECH [150 h]; PROCUREMENT<$50K 60 | 20,979.15 |  | 13930.65 | 0 | 0 | 100 |  | 0 | CHUDAKOV | 1 | 1 | D | D | EUGENE C |  |  |  |  |  |  |  | 2546655 |  | 13-007 | PE | 13-015 | PR | EJ |  |  | 14-001 |  |

Notes:
- 2546610: Steps: ___specs (done); ___vendor communication (done); ___testing
- 2546610a: Steps: ___specs (done); ___vendor communication (done); ___testing

| ID | WBS | Activity | Duration | Start | Finish | Predecessors | Complete | Remaining | Planned start | Planned finish | Total float | Free float | Calendar | Resources | Cost | Actual cost | Calculated Remaining Total Cost | MONTHLY EV COST | RESP - Responsibility | STRT%COMP for CM EVM | FNSH%COMP for CM EVM | HALL D Related Milestones | EVMS Reporting Codes | CAM RESPONSIBLE | CR 11-006 | CR 11-026 | CR 12-054 | CR 12-001 | CR 12-021 | Remaining Material Cost Based on % Compl | Claimed Material Cost Based on % Complet | Initial Claimed Material Calc | Claimed Material Divider | MARCH!!! | ReBaseline Actuals Adjustment | Original Activity ID Rebaseline | PRIOR MONTH EV COST | CR 13-007 | BOE Labor | CR 13-015 | Post Rebaseline | CR 14-001 |
| --- | --- | --- | --- | --- | --- | --- | --- | --- | --- | --- | --- | --- | --- | --- | --- | --- | --- | --- | --- | --- | --- | --- | --- | --- | --- | --- | --- | --- | --- | --- | --- | --- | --- | --- | --- | --- | --- | --- | --- | --- | --- | --- |
|  | 7 | **1.5.4.7 DETECTOR CABLING** |  | 2011-02-01 | 2014-01-31 |  |  |  |  |  |  |  |  |  |  |  |  |  |  |  |  |  |  |  |  |  |  |  |  |  |  |  |  |  |  |  |  |  |  |  |  |  |
| 1547005 |  | Cables - Low Voltage Cabling Development (Bcal,FDC&CDC) | 257d | 2011-02-01 A | 2012-02-13 A | 9-110M FS+64d | 100% |  |  |  |  |  |  | ELEC TECH [80 h]; ELEC ENG [80 h] | 8,987.87 | 8,987.87 | 0 | 8892 | CHUDAKOV | 1 | 1 | D | H | EUGENE C | 11-006 | 11-026 | 12-054F |  |  |  |  |  |  |  |  |  |  |  |  |  |  |  |
| 1547035 |  | Cables - Coax Signal Procurement Support FY11 | 89d | 2011-05-09 A | 2011-09-13 A | 9-110M | 100% |  |  |  |  |  |  | ELEC ENG [85.61 h]; ELEC TECH [85.61 h] | 9,515.55 | 9,515.55 | 0 | 9515.5515 | CHUDAKOV | 1 | 1 | D | H | EUGENE C | 11-006 | 11-026 | 12-054F | 12-001 | 12-021F |  |  |  |  |  |  |  |  |  |  |  |  |  |
| 1547035a |  | Cables - Coax Signal Procurement Support FY12 | 89d | 2011-05-09 A | 2011-09-13 A | 1547035 | 100% |  |  |  |  |  |  | ELEC ENG [74.39 h]; ELEC TECH [74.39 h] | 8,268.45 | 8,268.45 | 0 | 8531.7891 | CHUDAKOV | 1 | 1 | D | H | EUGENE C | 11-006 | 11-026 | 12-054F | 12-001 | 12-021F |  |  |  |  |  |  |  |  |  |  |  |  |  |
| 1547040 |  | Cables - Coax HV Procurement Support FY11 | 89d | 2011-05-09 A | 2011-09-13 A | 9-110M | 100% |  |  |  |  |  |  | ELEC ENG [85.61 h]; ELEC TECH [85.61 h] | 9,515.55 | 9,515.55 | 0 | 9515.5515 | CHUDAKOV | 1 | 1 | D | H | EUGENE C | 11-006 | 11-026 | 12-054F | 12-001 | 12-021F |  |  |  |  |  |  |  |  |  |  |  |  |  |
| 1547040a |  | Cables - Coax HV Procurement Support FY12 | 89d | 2011-05-09 A | 2011-09-13 A | 1547040 | 100% |  |  |  |  |  |  | ELEC ENG [74.39 h]; ELEC TECH [74.39 h] | 8,268.45 | 8,268.45 | 0 | 8531.7891 | CHUDAKOV | 1 | 1 | D | H | EUGENE C | 11-006 | 11-026 | 12-054F | 12-001 | 12-021F |  |  |  |  |  |  |  |  |  |  |  |  |  |
| 1547055 |  | Cables - Coax HV Tagger/Hodoscope | 166d | 2011-09-12 A | 2012-05-14 A | 1547050 FS-55d | 100% |  |  |  |  |  |  | PROCUREMENT<$50K 60 | 14,704.58 |  | 0 | 14704.58 | CHUDAKOV | 1 | 1 | D | D | EUGENE C | 11-006 | 11-026 |  |  | 12-021 | 0 | 14704.58 | 1470458 | 100 |  |  |  |  |  |  |  |  |  |
| 1547060 |  | Cables - Coax Signal Tagger/Hodoscope | 229d | 2011-09-12 A | 2012-08-13 A | 1547045 FS-55d | 100% |  |  |  |  |  |  | PROCUREMENT<$50K 60 | 15,994.45 |  | 0 | 15994.45 | CHUDAKOV | 1 | 1 | D | D | EUGENE C | 11-006 | 11-026 | 12-054F |  | 12-021 | 0 | 15994.45 | 1599445 | 100 |  |  |  |  |  |  |  |  |  |
| 1547065 |  | Cables - Coax HV Pair Spectrometer | 184d | 2011-09-12 A | 2012-06-11 A | 1547050 FS-55d | 100% |  |  |  |  |  |  | PROCUREMENT<$50K 60 | 3,869.63 |  | 0 | 3869.63 | CHUDAKOV | 1 | 1 | D | D | EUGENE C | 11-006 | 11-026 |  |  | 12-021 | 0 | 3869.63 | 386963 | 100 |  |  |  |  |  |  |  |  |  |
| 1547070 |  | Cables - Coax Signal Pair Spectrometer | 253d | 2011-09-12 A | 2012-09-17 A | 1547045 FS-55d | 100% |  |  |  |  |  |  | PROCUREMENT<$50K 60 | 2,579.75 |  | 0 | 2579.75 | CHUDAKOV | 1 | 1 | D | D | EUGENE C | 11-006 | 11-026 |  |  | 12-021 | 0 | 2579.75 | 257975 | 100 |  |  |  |  |  |  |  |  |  |
| 1547075 |  | Cables - Coax HV Start Counter | 184d | 2011-09-12 A | 2012-06-11 A | 1547050 FS-55d | 100% |  |  |  |  |  |  | PROCUREMENT<$50K 60 | 3,095.7 |  | 0 | 3095.7 | CHUDAKOV | 1 | 1 | D | D | EUGENE C | 11-006 | 11-026 | 12-054F |  | 12-021 | 0 | 3095.7 | 309570 | 100 |  |  |  |  |  |  |  |  |  |
| 1547080 |  | Cables - Coax Signal Start Counter | 204d | 2011-09-12 A | 2012-07-09 A | 1547045 FS-55d | 100% |  |  |  |  |  |  | PROCUREMENT<$50K 60 | 2,063.8 |  | 0 | 2063.8 | CHUDAKOV | 1 | 1 | D | D | EUGENE C | 11-006 | 11-026 | 12-054F |  | 12-021 | 0 | 2063.8 | 206380 | 100 |  |  |  |  |  |  |  |  |  |
| 1547085 |  | Cables - LV BCAL | 324d | 2011-09-12 A | 2012-12-17 A | 1547050 FS-55d | 100% |  | 2011-09-12 | 2013-01-04 |  |  |  | PROCUREMENT<$50K 60 | 3,714.84 |  | 0 | 3714.84 | CHUDAKOV | 1 | 1 | D | D | EUGENE C | 11-006 | 11-026 | 12-054F |  | 12-021 | 0 | 3714.84 | 371484 | 100 |  |  |  |  |  |  |  |  |  |
| 1547090 |  | Cables - Bias BCAL | 324d | 2011-09-12 A | 2012-12-17 A | 1547045 FS-35d | 100% |  | 2011-09-12 | 2013-01-04 |  |  |  | PROCUREMENT<$50K 60 | 5,572.26 |  | 0 | 5572.26 | CHUDAKOV | 1 | 1 | D | D | EUGENE C | 11-006 | 11-026 | 12-054F |  | 12-021 | 0 | 5572.26 | 557226 | 100 |  |  |  |  |  |  |  |  |  |
| 1547095 |  | Cables - Coax Signal BCAL | 229d | 2011-09-12 A | 2012-08-13 A | 1547045 FS-55d | 100% |  |  |  |  |  |  | PROCUREMENT<$50K 60; PROCUREMENT>$50K 69 | 99,062.4 |  | 0 | 99062.4 | CHUDAKOV | 1 | 1 | D | D | EUGENE C | 11-006 | 11-026 | 12-054F |  | 12-021 | 0 | 99062.4 | 9906240 | 100 |  |  |  |  |  |  |  |  |  |
| 1547100 |  | Cables - Coax HV TOF | 253d | 2011-09-12 A | 2012-09-17 A | 1547050 FS-55d | 100% |  |  |  |  |  |  | PROCUREMENT<$50K 60 | 13,001.94 |  | 0 | 13001.94 | CHUDAKOV | 1 | 1 | D | D | EUGENE C | 11-006 | 11-026 | 12-054F |  | 12-021 | 0 | 13001.94 | 1300194 | 100 |  |  |  |  |  |  |  |  |  |
| 1547105 |  | Cables - Coax Signal TOF | 204d | 2011-09-12 A | 2012-07-09 A | 1547045 FS-55d | 100% |  |  |  |  |  |  | PROCUREMENT<$50K 60 | 8,667.96 |  | 0 | 8667.96 | CHUDAKOV | 1 | 1 | D | D | EUGENE C | 11-006 | 11-026 | 12-054F |  | 12-021 | 0 | 8667.96 | 866796 | 100 |  |  |  |  |  |  |  |  |  |
| 1547110 |  | Cables - Coax Signal FCAL | 253d | 2011-09-12 A | 2012-09-17 A | 1547045 FS-55d | 100% |  |  |  |  |  |  | PROCUREMENT<$50K 60; PROCUREMENT>$50K 69 | 56,754.5 |  | 0 | 56754.5 | CHUDAKOV | 1 | 1 | D | D | EUGENE C | 11-006 | 11-026 | 12-054F |  | 12-021 | 0 | 56754.5 | 5675450 | 100 |  |  |  |  |  |  |  |  |  |
| 1547020 |  | Cables - Low Voltage Distribution Development (Bcal,FDC&CDC) | 141d | 2011-10-17 A | 2012-05-14 A | 1547005 FS-30d | 100% |  |  |  |  |  |  | ELEC ENG [80 h]; ELEC TECH [320 h] | 19,766.4 | 19,766.4 | 0 | 19156.8 | CHUDAKOV | 1 | 1 | D | H | EUGENE C | 11-006 | 11-026 | 12-054F |  |  |  |  |  |  |  |  |  |  |  |  |  |  |  |
| 1547010 |  | Cables - Low Voltage Cabling Procurement Prep (Bcal,FDC&CDC) | 148d | 2011-11-01 A | 2012-06-11 A | 1547005 FS-15d | 100% |  |  |  |  |  |  | ELEC ENG [240 h] | 16,934.4 | 16,934.4 | 0 | 16411.2 | CHUDAKOV | 1 | 1 | D | H | EUGENE C | 11-006 | 11-026 | 12-054F |  |  |  |  |  |  |  |  |  |  |  |  |  |  |  |
| 1547045 |  | Cables - Coax Signal Acceptance Tests | 46d | 2011-12-01 A | 2012-02-13 A | 1547035 FS+35d, 1547035a FS+35d | 100% |  |  |  |  |  |  | ELEC TECH [240 h] | 10,591.2 | 10,591.2 | 0 | 10591.2 | CHUDAKOV | 1 | 1 | D | H | EUGENE C | 11-006 | 11-026 | 12-054F |  | 12-021F |  |  |  |  |  |  |  |  |  |  |  |  |  |
| 1547050 |  | Cables - Coax HV Acceptance Tests | 46d | 2011-12-01 A | 2012-02-13 A | 1547040a FS+35d | 100% |  |  |  |  |  |  | ELEC TECH [240 h] | 10,591.2 | 10,591.2 | 0 | 10591.2 | CHUDAKOV | 1 | 1 | D | H | EUGENE C | 11-006 | 11-026 | 12-054F |  | 12-021F |  |  |  |  |  |  |  |  |  |  |  |  |  |
| 1547015 |  | Cables - Low Voltage Assemblies (Bcal,FDC&CDC) | 148d | 2012-04-16 A | 2012-11-12 A | 1547010 FS-50d | 100% |  |  |  |  |  |  | PROCUREMENT<$50K 60 NO ESCALATION FY12 | 45,000 |  | 0 | 45000 | CHUDAKOV | 1 | 1 | D | D | EUGENE C | 11-006 | 11-026 | 12-054F |  |  | 0 | 45000 | 4500000 | 100 |  |  |  |  |  |  |  |  |  |
| 1547030 |  | Cables - Low Voltage Distribution Supply Cables (Bcal,FDC&CDC) | 115d | 2012-06-01 A | 2012-11-12 A | 1547025 FS-100d | 100% |  |  |  |  |  |  | PROCUREMENT<$50K 60 NO ESCALATION FY12 | 10,000 |  | 0 | 10000 | CHUDAKOV | 1 | 1 | D | D | EUGENE C | 11-006 | 11-026 | 12-054F |  |  | 0 | 10000 | 1000000 | 100 |  |  |  |  |  |  |  |  |  |
| 1547025 |  | Cables - Low Voltage Distribution Chassis (Bcal,FDC&CDC) | 137d | 2012-06-02 A | 2013-07-15 A | 1547020 | 100% |  | 2012-06-05 | 2012-12-17 |  |  |  | PROCUREMENT<$50K 60 | 21,000 |  | 4200 | 21000 | CHUDAKOV | 1 | 1 | D | D | EUGENE C | 11-006 | 11-026 | 12-054F |  |  | 0 | 21000 | 2100000 | 100 | XX |  |  |  |  |  |  |  |  |
| 1547185 |  | Cables - Signal Label and Bundle BCAL | 89d | 2013-04-01 A | 2013-07-15 A | 1547095, 9-130M FS+110d | 100% |  | 2013-05-01 | 2013-09-05 |  |  |  | ELEC TECH [640 h] | 29,145.6 | 29,145.6 | 14572.8 | 29145.6 | CHUDAKOV | 1 | 1 | D | H | EUGENE C | 11-006 | 11-026 | 12-054 |  | 12-021 |  |  |  |  |  |  |  |  |  |  |  |  |  |
| 1547115 |  | Cables - HV Label and Bundle Tagger/Hodoscope | 18d | 2013-06-01 A | 2013-07-15 A | 1547055 FS+55d, 9-130M FS+100d | 100% |  | 2013-07-01 | 2013-07-25 |  |  |  | ELEC TECH [80 h] | 3,643.2 | 3,643.2 | 1821.6 | 3643.2 | CHUDAKOV | 1 | 1 | D | H | EUGENE C | 11-006 | 11-026 | 12-054 |  | 12-021 |  |  |  |  |  |  |  |  |  |  |  |  |  |
| 1547120 |  | Cables - Signal Label and Bundle Tagger/Hodoscope | 18d | 2013-06-01 A | 2013-07-15 A | 1547060, 9-130M FS+100d | 100% |  | 2013-07-01 | 2013-07-25 |  |  |  | ELEC TECH [80 h] | 3,643.2 | 3,643.2 | 1821.6 | 3643.2 | CHUDAKOV | 1 | 1 | D | H | EUGENE C | 11-006 | 11-026 | 12-054 |  | 12-021 |  |  |  |  |  |  |  |  |  |  |  |  |  |
| 1547125 |  | Cables - HV Label and Bundle Pair Spectrometer | 10d | 2013-06-01 A | 2013-07-15 A | 1547065 FS+18d, 9-130M FS+160d | 100% |  | 2013-07-01 | 2013-07-15 |  |  |  | ELEC TECH [40 h] | 1,821.6 | 1,821.6 | 910.8 | 1821.6 | CHUDAKOV | 1 | 1 | D | H | EUGENE C | 11-006 | 11-026 | 12-054 |  | 12-021 |  |  |  |  |  |  |  |  |  |  |  |  |  |
| 1547130 |  | Cables - Signal Label and Bundle Pair Spectrometer | 10d | 2013-06-01 A | 2013-07-15 A | 1547070 FS+63d, 9-130M FS+165d | 100% |  | 2013-07-01 | 2013-07-15 |  |  |  | ELEC TECH [40 h] | 1,821.6 | 1,821.6 | 910.8 | 1821.6 | CHUDAKOV | 1 | 1 | D | H | EUGENE C | 11-006 | 11-026 |  |  | 12-021 |  |  |  |  |  |  |  |  |  |  |  |  |  |
| 1547135 |  | Cables - HV Label and Bundle Start Counter | 10d | 2013-06-01 A | 2013-07-15 A | 9-130M FS+110d, 1547075 FS+33d | 100% |  | 2013-07-01 | 2013-07-15 |  |  |  | ELEC TECH [40 h] | 1,821.6 | 1,821.6 | 910.8 | 1821.6 | CHUDAKOV | 1 | 1 | D | H | EUGENE C | 11-006 | 11-026 | 12-054 |  | 12-021 |  |  |  |  | XX |  |  |  |  |  |  |  |  |
| 1547140 |  | Cables - Signal Label and Bundle Start Counter | 9d | 2013-06-01 A | 2013-07-15 A | 9-130M FS+110d, 1547080 FS+73d | 100% |  | 2013-07-01 | 2013-07-12 |  |  |  | ELEC TECH [40 h] | 1,821.6 | 1,821.6 | 910.8 | 1821.6 | CHUDAKOV | 1 | 1 | D | H | EUGENE C | 11-006 | 11-026 | 12-054 |  | 12-021 |  |  |  |  | XX |  |  |  |  |  |  |  |  |
| 1547155 |  | Cables - Signal Label and Bundle CDC | 20d | 2013-06-01 A | 2013-07-15 A | 1547140 FS-10d | 100% |  | 2013-07-15 | 2013-08-09 |  |  |  | ELEC TECH [80 h] | 3,643.2 | 3,643.2 | 1821.6 | 3643.2 | CHUDAKOV | 1 | 1 | D | H | EUGENE C | 11-006 | 11-026 | 12-054F |  | 12-021 |  |  |  |  | XX |  |  |  |  |  |  |  |  |
| 1547170 |  | Cables - Signal Label and Bundle FDC | 48d | 2013-06-01 A | 2013-08-30 A | 1547155 FS-20d | 100% |  | 2013-07-30 | 2013-10-04 |  |  |  | ELEC TECH [200 h] | 9,132.17 | 9,108 | 4554 | 9108 | CHUDAKOV | 1 | 1 | D | H | EUGENE C | 11-006 | 11-026 | 12-054F |  | 12-021 |  |  |  |  |  |  |  |  |  |  |  |  |  |
| 1547195 |  | Cables - Signal Label and Bundle TOF | 20d | 2013-06-01 A | 2013-08-30 A | 9-130M FS+60d, 1547105, 1547120 FS-20d | 100% |  | 2013-07-26 | 2013-08-22 |  |  |  | ELEC TECH [80 h] | 3,643.2 | 3,643.2 | 1821.6 | 3643.2 | CHUDAKOV | 1 | 1 | D | H | EUGENE C | 11-006 | 11-026 | 12-054 |  | 12-021 |  |  |  |  |  |  |  |  |  |  |  |  |  |
| 1547200 |  | Cables - Signal Label and Bundle FCAL | 97d | 2013-06-01 A | 2013-06-17 A | 1547110, 9-130M FS+110d | 100% |  | 2013-07-01 | 2013-11-14 |  |  |  | ELEC TECH [400 h] | 18,413.32 | 18,216 | 0 | 18216 | CHUDAKOV | 1 | 1 | D | H | EUGENE C | 11-006 | 11-026 | 12-054 |  | 12-021 |  |  |  |  |  |  |  |  |  |  |  |  |  |
| 1547145 |  | Cables - LV Label and Bundle CDC | 10d | 2013-07-01 A | 2013-07-15 A | 1547015, 1547030, 1547140 | 100% |  | 2013-08-14 | 2013-08-27 |  |  |  | ELEC TECH [40 h] | 1,821.6 | 1,821.6 | 1821.6 | 1821.6 | CHUDAKOV | 1 | 1 | D | H | EUGENE C | 11-006 | 11-026 | 12-054 |  | 12-021 |  |  |  |  | XX |  |  |  |  |  |  |  |  |
| 1547160 |  | Cables - LV Label and Bundle FDC | 12d | 2013-07-01 A | 2013-07-15 A | 1547145 | 100% |  | 2013-08-28 | 2013-09-13 |  |  |  | ELEC TECH [120 h] | 5,464.8 | 5,464.8 | 5464.8 | 5464.8 | CHUDAKOV | 1 | 1 | D | H | EUGENE C | 11-006 | 11-026 | 12-054F |  | 12-021 |  |  |  |  |  |  |  |  |  |  |  |  |  |
| 1547190 |  | Cables - HV Label and Bundle TOF | 19d | 2013-07-15 A | 2013-08-30 A | 1547165 FS-25d, 1547100, 9-130M FS+60d | 100% |  | 2013-09-13 | 2013-10-09 |  |  |  | ELEC TECH [80 h] | 3,685.94 | 3,643.2 | 3643.2 | 3643.2 | CHUDAKOV | 1 | 1 | D | H | EUGENE C | 11-006 | 11-026 | 12-054 |  | 12-021 |  |  |  |  |  |  |  |  |  |  |  |  |  |
| 1547175 |  | Cables - LV Label and Bundle BCAL | 8d | 2013-08-01 A | 2013-08-30 A | 1547160, 1547085 | 100% |  | 2013-08-01 | 2013-08-12 |  |  |  | ELEC TECH [40 h] | 1,821.6 | 1,821.6 | 1821.6 | 1821.6 | CHUDAKOV | 1 | 1 | D | H | EUGENE C | 11-006 | 11-026 | 12-054F |  | 12-021 |  |  |  |  |  |  |  |  |  |  |  |  |  |
| 1547180 |  | Cables - Bias Label and Bundle BCAL | 10d | 2013-08-13 A | 2013-08-30 A | 1547090, 1547175 | 100% |  | 2013-08-13 | 2013-08-26 |  |  |  | ELEC TECH [40 h] | 1,821.6 | 1,821.6 | 1821.6 | 1821.6 | CHUDAKOV | 1 | 1 | D | H | EUGENE C | 11-006 | 11-026 | 12-054F |  | 12-021 |  |  |  |  |  |  |  |  |  |  |  |  |  |
| 1547150 |  | Cables - HV Label and Bundle CDC | 10d | 2013-08-30 A | 2013-08-30 A | 9-130M FS+60d, 1547135 | 100% |  | 2013-09-03 | 2013-09-16 |  |  |  | ELEC TECH [40 h] | 1,821.6 | 1,821.6 | 1821.6 | 1821.6 | CHUDAKOV | 1 | 1 | D | H | EUGENE C | 11-006 | 11-026 | 12-054 |  | 12-021 |  |  |  |  | XX |  |  |  |  |  |  |  |  |
| 1547165 |  | Cables - HV Label and Bundle FDC | 10d | 2013-08-30 A | 2013-08-30 A | 9-130M FS+60d, 1547150 | 100% |  | 2013-09-17 | 2013-09-30 |  |  |  | ELEC TECH [40 h] | 1,821.6 | 1,821.6 | 1821.6 | 1821.6 | CHUDAKOV | 1 | 1 | D | H | EUGENE C | 11-006 | 11-026 | 12-054 |  | 12-021 |  |  |  |  | XX |  |  |  |  |  |  |  |  |
| 1547205 |  | Re-Baseline Actuals Adjustment | 1d | 2013-08-30 A | 2013-08-30 A |  | 100% |  | 2013-09-03 | 2013-09-03 |  |  |  | PROCUREMENT>$50K 69 NO ESCALATION | -102,247.05 |  |  |  |  |  |  |  |  |  |  |  |  |  |  |  |  |  | 100 |  | ADJ |  |  |  |  |  |  |  |
| 2547165 |  | Cables - HV Label and Bundle FDC (8) FY13 | 11d | 2013-09-03 A | 2013-11-22 | 9-130M FS+237d | 50% | 16d | 2013-10-01 | 2013-10-15 | 19d | 3d | 8/5 M-F w/JLAB Holidays ReBaseline | ELEC TECH [27.5 h] | 1,292.22 | 695.75 |  | 375.705 | CHUDAKOV | 1 | 1 | D | U | EUGENE C | 11-006 | 11-026 | 12-054 |  | 12-021 |  |  |  |  |  |  | 2547165 | 250.47 | 13-007 | PE | 13-015 | PR |  |
| 2547165a |  | Cables - HV Label and Bundle FDC (8) FY14 | 5d | 2013-09-03 A | 2013-11-22 | 2547165 FS-20d | 50% | 16d | 2013-10-01 | 2013-10-07 | 19d | 3d | 8/5 M-F w/JLAB Holidays ReBaseline | ELEC TECH [12.5 h] | 587.38 | 316.25 |  | 176.2125 | CHUDAKOV | 1 | 1 | D | U | EUGENE C | 11-006 | 11-026 | 12-054 |  | 12-021 |  |  |  |  |  |  | 2547165 | 117.475 | 13-007 | PE | 13-015 | PR | 14-001 |
| 2547170 |  | Cables - Signal Label and Bundle FDC (528) FY13 | 20d | 2013-09-03 A | 2013-11-27 | 9-130M FS+228d | 90% | 19d | 2013-10-01 | 2013-10-28 | 16d | 0d | 8/5 M-F w/JLAB Holidays ReBaseline | ELEC TECH [51.28 h] | 2,409.65 | 1,197.59 |  | 1167.6456 | CHUDAKOV | 1 | 1 | D | U | EUGENE C | 11-006 | 11-026 | 12-054F |  | 12-021 |  |  |  |  |  |  | 2547170 | 934.11648 | 13-007 | PE | 13-015 | PR |  |
| 2547170a |  | Cables - Signal Label and Bundle FDC (528) FY14 | 19d | 2013-09-03 A | 2013-11-27 | 2547170 FS-20d | 90% | 19d | 2013-10-01 | 2013-10-25 | 16d | 0d | 8/5 M-F w/JLAB Holidays ReBaseline | ELEC TECH [48.72 h] | 2,289.35 | 1,137.8 |  | 1144.6764 | CHUDAKOV | 1 | 1 | D | U | EUGENE C | 11-006 | 11-026 | 12-054F |  | 12-021 |  |  |  |  |  |  | 2547170 | 915.74112 | 13-007 | PE | 13-015 | PR | 14-001 |
| 2547175 |  | Cables - LV Label and Bundle BCAL (24) | 20d | 2013-09-03 A | 2013-10-21 A | 9-130M FS+228d | 100% |  | 2013-10-01 | 2013-10-28 |  |  | 8/5 M-F w/JLAB Holidays ReBaseline | ELEC TECH [28 h] | 1,315.72 | 1,302.83 |  | 1211.364 | CHUDAKOV | 1 | 1 | D | U | EUGENE C | 11-006 | 11-026 | 12-054F |  | 12-021 |  |  |  |  |  |  | 2547175 | 63.756 | 13-007F | PE | 13-015 | PR |  |
| 2547180 |  | Cables - Bias Label and Bundle BCAL (36) | 20d | 2013-09-03 A | 2013-10-21 A | 2547175 FS-20d | 100% |  | 2013-10-01 | 2013-10-28 |  |  | 8/5 M-F w/JLAB Holidays ReBaseline | ELEC TECH [22 h] | 1,033.78 | 1,023.65 |  | 500.94 | CHUDAKOV | 1 | 1 | D | U | EUGENE C | 11-006 | 11-026 | 12-054F |  | 12-021 |  |  |  |  |  |  | 2547180 | 500.94 | 13-007F | PE | 13-015 | PR |  |
| 2547190 |  | Cables - HV Label and Bundle TOF (168) FY13 | 20d | 2013-09-03 A | 2014-01-31 | 2547165a FS-25d, 2547165 FS-25d | 55% | 55d | 2013-10-01 | 2013-10-28 | 127d | 25d | 8/5 M-F w/JLAB Holidays ReBaseline | ELEC TECH [6.53 h] | 306.84 | 132.7 |  | 148.6881 | CHUDAKOV | 1 | 1 | D | U | EUGENE C | 11-006 | 11-026 | 12-054 |  | 12-021 |  |  |  |  |  |  | 2547190 | 14.86881 | 13-007 | PE | 13-015 | PR |  |
| 2547190a |  | Cables - HV Label and Bundle TOF (168) FY14 | 78d | 2013-09-03 A | 2014-01-31 | 2547165a FS-25d, 2547190 FS-80d | 55% | 55d | 2013-10-01 | 2014-01-31 | 127d | 40.5d | 8/5 M-F w/JLAB Holidays ReBaseline | ELEC TECH [25.47 h] | 1,196.84 | 517.6 |  | 598.41765 | CHUDAKOV | 1 | 1 | D | U | EUGENE C | 11-006 | 11-026 | 12-054 |  | 12-021 |  |  |  |  |  |  | 2547190 | 59.841765 | 13-007 | PE | 13-015 | PR | 14-001 |
| 2547200 |  | Cables - Signal Label and Bundle TOF (168) FY13 | 20d | 2013-09-03 A | 2014-01-31 | 2547190a FS-95.5d, 2547190 FS-98d | 50% | 55d | 2013-10-01 | 2013-10-28 | 127d | 25d | 8/5 M-F w/JLAB Holidays ReBaseline | ELEC TECH [6.53 h] | 306.84 | 132.7 |  | 142.740576 | CHUDAKOV | 1 | 1 | D | U | EUGENE C | 11-006 | 11-026 | 12-054 |  | 12-021 |  |  |  |  |  |  | 2547200 | 5.947524 | 13-007 | PE | 13-015 | PR |  |
| 2547200a |  | Cables - Signal Label and Bundle TOF (168) FY14 | 78d | 2013-09-03 A | 2014-01-31 | 2547190a FS-98d, 2547200 FS-80d | 50% | 55d | 2013-09-03 | 2014-01-02 | 127d | 63d | 8/5 M-F w/JLAB Holidays ReBaseline | ELEC TECH [25.47 h] | 1,187.37 | 517.6 |  | 574.480944 | CHUDAKOV | 1 | 1 | D | U | EUGENE C | 11-006 | 11-026 | 12-054 |  | 12-021 |  |  |  |  |  |  | 2547200 | 23.936706 | 13-007 | PE | 13-015 | PR | 14-001 |
| 2547135 |  | Cables - HV Label and Bundle CDC (6) | 25d | 2013-11-01 | 2013-12-09 | 9-140M |  |  |  |  | 111d | 0d | 8/5 M-F w/JLAB Holidays ReBaseline | ELEC TECH [40 h] | 1,879.6 |  |  | 0 | CHUDAKOV | 1 | 1 | D | U | EUGENE C | 11-006 | 11-026 | 12-054 |  | 12-021 |  |  |  |  |  |  | 2547135 |  | 13-007 | PE | 13-015 | PR | 14-001 |

| ID | WBS | Activity | Duration | Start | Finish | Predecessors | Complete | Planned start | Planned finish | Total float | Free float | Calendar | Resources | Cost | Actual cost | Calculated Remaining Total Cost | MONTHLY EV COST | RESP - Responsibility | STRT%COMP for CM EVM | FNSH%COMP for CM EVM | HALL D Related Milestones | EVMS Reporting Codes | CAM RESPONSIBLE | CR 11-006 | CR 11-026 | MARCH!!! | CR 12-047 | CR 12-016 | CR 12-021 | Claimed Material Divider | ReBaseline Actuals Adjustment | Original Activity ID Rebaseline | PRIOR MONTH EV COST | CR 11-049 | CR 12-054 | BOE Labor | CR 13-015 | Post Rebaseline | CR 14-001 | CR 12-044 | Remaining Material Cost Based on % Compl | Claimed Material Cost Based on % Complet | Initial Claimed Material Calc | Advance Purchase Plan > 500K | CR 08-016 | 12 GEV MAJOR PROCUREMENT CATAGORY | CR 09-014 | CR 11-004 | LOE Divider | LOE Multiplier | CR 07-024 | 12 GeV 2nd level Critical Path | Activities with Steps | CR 09-027 | CR 09-027 Repair | CR 11-030 | LOE % Pre Calc | LOE % | CR 10-024 | Specification | CR 12-053 | BOE Expenses |
| --- | --- | --- | --- | --- | --- | --- | --- | --- | --- | --- | --- | --- | --- | --- | --- | --- | --- | --- | --- | --- | --- | --- | --- | --- | --- | --- | --- | --- | --- | --- | --- | --- | --- | --- | --- | --- | --- | --- | --- | --- | --- | --- | --- | --- | --- | --- | --- | --- | --- | --- | --- | --- | --- | --- | --- | --- | --- | --- | --- | --- | --- | --- |
|  | 8 | **1.5.4.8 FULL CRATE CHECKS** |  | 2013-03-01 | 2014-02-27 |  |  |  |  |  |  |  |  |  |  |  |  |  |  |  |  |  |  |  |  |  |  |  |  |  |  |  |  |  |  |  |  |  |  |  |  |  |  |  |  |  |  |  |  |  |  |  |  |  |  |  |  |  |  |  |  |  |
| 1548030 |  | Full Crate Check - Pre Installation,Lab,Install Mods,Test,Log&Label High Voltage | 20d | 2013-03-01 A | 2013-04-15 A | 1545080, 1545085 FS+100d | 100% | 2013-04-01 | 2013-04-26 |  |  |  | ELEC TECH [80 h]; ELEC ENG [20 h] | 5,099.4 | 5,099.4 | 0 | 4941.6 | CHUDAKOV | 1 | 1 | D | H | EUGENE C | 11-006 | 11-026 | XX |  |  |  |  |  |  |  |  |  |  |  |  |  |  |  |  |  |  |  |  |  |  |  |  |  |  |  |  |  |  |  |  |  |  |  |  |
| 1548015 |  | Full Crate Check - Pre Installation,Lab,Install Mods,Test,Log&Label VXS fADC250 | 15d | 2013-03-04 A | 2013-05-13 A | 1541059, 1544015, 1541057 FS-5d | 100% | 2013-04-01 | 2013-04-19 |  |  |  | ELEC TECH [200 h]; ELEC ENG [20 h] | 10,564.2 | 10,564.2 | 0 | 10564.2 | CHUDAKOV | 1 | 1 | D | H | EUGENE C | 11-006 | 11-026 |  | 12-047 |  |  |  |  |  |  |  |  |  |  |  |  |  |  |  |  |  |  |  |  |  |  |  |  |  |  |  |  |  |  |  |  |  |  |  |
| 1548010 |  | Full Crate Check - Pre Installation,Lab,Install Mods,Test,Log&Label VME64x Discriminator | 50d | 2013-07-01 A | 2013-07-15 A | 1544025, 1544040, 1545030a, 1545028, 1546345 | 100% | 2013-08-01 | 2013-10-10 |  |  |  | ELEC TECH [80 h]; ELEC ENG [20 h] | 5,125.38 | 5,099.4 | 5099.4 | 5099.4 | CHUDAKOV | 1 | 1 | D | H | EUGENE C | 11-006 | 11-026 |  |  | 12-016 | 12-021 |  |  |  |  |  |  |  |  |  |  |  |  |  |  |  |  |  |  |  |  |  |  |  |  |  |  |  |  |  |  |  |  |  |
| 1548035 |  | Full Crate Check - Pre Installation,Lab,Install Mods,Test,Log&Label Low Voltage | 8d | 2013-07-01 A | 2013-08-12 A | 1546460, 1545120a, 1546565 FS-100d, 1546465 FS-20d, 1546555, 1546560, 1545125a, 1546550, 1546450, 1546455 | 100% | 2013-08-26 | 2013-09-05 |  |  |  | ELEC TECH [80 h]; ELEC ENG [20 h] | 5,099.4 | 5,099.4 | 5099.4 | 5099.4 | CHUDAKOV | 1 | 1 | D | H | EUGENE C | 11-006 | 11-026 |  |  |  | 12-021 |  |  |  |  |  |  |  |  |  |  |  |  |  |  |  |  |  |  |  |  |  |  |  |  |  |  |  |  |  |  |  |  |  |
| 1548040 |  | Re-Baseline Actuals Adjustment | 1d | 2013-08-30 A | 2013-08-30 A |  | 100% | 2013-09-03 | 2013-09-03 |  |  |  | PROCUREMENT>$50K 69 NO ESCALATION | -12,809.88 |  |  |  |  |  |  |  |  |  |  |  |  |  |  |  | 100 | ADJ |  |  |  |  |  |  |  |  |  |  |  |  |  |  |  |  |  |  |  |  |  |  |  |  |  |  |  |  |  |  |  |
| 2548025 |  | Full Crate Check - Pre Installation,Lab,Install Mods,Test,Log&Label VXS F1TDC FY13 | 16d | 2013-09-03 A | 2013-10-21 A | 9-130M FS+232d | 100% | 2013-10-01 | 2013-10-22 |  |  | 8/5 M-F w/JLAB Holidays ReBaseline | ELEC TECH [9.41 h]; ELEC ENG [9.41 h] | 1,149.15 | 1,140.97 |  | 222.7347 | CHUDAKOV | 1 | 1 | D | U | EUGENE C | 11-006 | 11-026 |  |  |  | 12-021 |  |  | 2548025 | 890.9388 | 11-049 | 12-054 | PE | 13-015 | PR |  |  |  |  |  |  |  |  |  |  |  |  |  |  |  |  |  |  |  |  |  |  |  |  |
| 2548025a |  | Full Crate Check - Pre Installation,Lab,Install Mods,Test,Log&Label VXS F1TDC FY14 | 52d | 2013-09-03 A | 2013-10-21 A | 2548025 FS-75d | 100% | 2013-10-01 | 2013-12-13 |  |  | 8/5 M-F w/JLAB Holidays ReBaseline | ELEC TECH [30.59 h]; ELEC ENG [30.59 h] | 3,735.65 | 3,700.7 |  | 747.13016 | CHUDAKOV | 1 | 1 | D | U | EUGENE C | 11-006 | 11-026 |  |  |  | 12-021 |  |  | 2548025 | 2988.52064 | 11-049 | 12-054 | PE | 13-015 | PR | 14-001 |  |  |  |  |  |  |  |  |  |  |  |  |  |  |  |  |  |  |  |  |  |  |  |
| 2548020 |  | Full Crate Check - Pre Installation,Lab,Install Mods,Test,Log&Label VXS fADC125 FY13 | 11d | 2013-11-11 | 2013-11-25 | 2541145 FS-88d, 2541120a FS-68d, 2541145a FS-88d, 2541120 FS-10d |  |  |  | 140d | 0d | 8/5 M-F w/JLAB Holidays ReBaseline | ELEC TECH [6.47 h]; ELEC ENG [6.47 h] | 790.12 |  |  | 0 | CHUDAKOV | 1 | 1 | D | U | EUGENE C | 11-006 | 11-026 |  |  |  | 12-021 |  |  | 2548020 |  |  | 12-054 | PE | 13-015 | PR |  | 12-044 |  |  |  |  |  |  |  |  |  |  |  |  |  |  |  |  |  |  |  |  |  |  |
| 2548020a |  | Full Crate Check - Pre Installation,Lab,Install Mods,Test,Log&Label VXS fADC125 FY14 | 57d | 2013-11-26 | 2014-02-27 | 2548020 |  |  |  | 140d | 26d | 8/5 M-F w/JLAB Holidays ReBaseline | ELEC TECH [33.53 h]; ELEC ENG [33.53 h] | 4,094.68 |  |  | 0 | CHUDAKOV | 1 | 1 | D | U | EUGENE C | 11-006 | 11-026 |  |  |  | 12-021 |  |  | 2548020 |  |  | 12-054 | PE | 13-015 | PR | 14-001 | 12-044 |  |  |  |  |  |  |  |  |  |  |  |  |  |  |  |  |  |  |  |  |  |  |
|  | 5 | **1.5.5 BEAMLINE** |  | 2009-07-03 | 2015-04-01 |  |  |  |  |  |  |  |  |  |  |  |  |  |  |  |  |  |  |  |  |  |  |  |  |  |  |  |  |  |  |  |  |  |  |  |  |  |  |  |  |  |  |  |  |  |  |  |  |  |  |  |  |  |  |  |  |  |
|  | 1 | **1.5.5.1 TAGGER** |  | 2009-07-03 | 2014-04-01 |  |  |  |  |  |  |  |  |  |  |  |  |  |  |  |  |  |  |  |  |  |  |  |  |  |  |  |  |  |  |  |  |  |  |  |  |  |  |  |  |  |  |  |  |  |  |  |  |  |  |  |  |  |  |  |  |  |
|  | 1 | **1.5.5.1.1 TAGGING MAGNET** |  | 2009-07-03 | 2013-12-17 |  |  |  |  |  |  |  |  |  |  |  |  |  |  |  |  |  |  |  |  |  |  |  |  |  |  |  |  |  |  |  |  |  |  |  |  |  |  |  |  |  |  |  |  |  |  |  |  |  |  |  |  |  |  |  |  |  |
| 15511070 |  | Proc Quad (TAGGING Mag) | 31d | 2009-07-03 A | 2009-08-17 A | 9-090M FS+120d | 100% | 2009-07-06 | 2009-08-17 |  |  |  | PROCUREMENT<$50K 60 | 20,000 |  | 0 | 20000 | CHUDAKOV | 1 | 1 | D | D | EUGENE C | 11-006 | 11-026 |  |  |  | 12-021F | 100 |  |  |  |  |  |  |  |  |  |  | 0 | 20000 | 2000000 | APP | 08-016 | 5511 | 09-014 | 11-004 |  |  |  |  |  |  |  |  |  |  |  |  |  |  |
| 15511010E |  | FY10 Travel (TAGGING Mag) | 248d | 2009-10-01 A | 2010-09-30 A | 9-100M | 100% |  |  |  |  |  | TRAVEL | 6,074.08 |  | 0 | 6074.083289 | CHUDAKOV | 1 | 1 | D | E | EUGENE C | 11-006 | 11-026 |  |  |  |  |  |  |  |  |  |  |  |  |  |  |  |  |  |  |  |  |  |  |  | 100 | 100 | 07-024 |  |  |  |  |  |  |  |  |  |  |  |
| 15511002 |  | Prepare Procurements/Fabrication Packages 2010 ((TAGGING Mag) | 281d | 2010-01-11 A | 2011-02-28 A | 9-100M | 100% |  |  |  |  |  | MECH ENG [360 h]; MECH DES [360 h] | 40,432.32 | 40,432.32 | 0 | 39992.4 | CHUDAKOV | 1 | 1 | D | S | EUGENE C | 11-006 | 11-026 |  |  |  |  |  |  |  |  |  |  |  |  |  |  |  |  |  |  |  |  |  | 09-014 |  |  |  | 07-024 | 2 | ST | 09-027 | 09-027 | 11-030 |  |  |  |  |  |  |
| 15511005 |  | Drawings for Yoke Steel (TAGGING Mag) | 123d | 2010-03-29 A | 2010-09-20 A | 12351055M, 9-100M FS+120d | 100% |  |  |  |  |  | MECH ENG [160 h]; MECH DES [440 h]; CONTRB UNIV LBR [240 h]; VISTNG USERS [880 h] | 46,413.6 | 46,413.6 | 0 | 46413.6 | CHUDAKOV | 1 | 1 | D | H | EUGENE C | 11-006 | 11-026 |  |  |  |  |  |  |  |  |  |  |  |  |  |  |  |  |  |  |  |  |  | 09-014 |  |  |  |  |  |  |  |  | 11-030 |  |  |  |  |  |  |
| 15511010 |  | Drawings for Coils (TAGGING Mag) | 123d | 2010-05-03 A | 2010-10-25 A | 9-100M FS+120d, 15511005 FS-120d | 100% |  |  |  |  |  | PD UNIV STUDNT [880 h]; MECH ENG [160 h]; MECH DES [440 h]; VISTNG USERS [880 h]; CONTRB UNIV LBR [240 h] | 55,474.67 | 55,474.67 | 0 | 55231.2 | CHUDAKOV | 1 | 1 | D | H | EUGENE C | 11-006 | 11-026 |  |  |  |  |  |  |  |  |  |  |  |  |  |  |  |  |  |  |  |  |  | 09-014 |  |  |  |  |  |  |  |  | 11-030 |  |  |  |  |  |  |
| 15511025 |  | Dsgn Stands for Mag (TAGGING Mag) | 387d | 2010-06-21 A | 2012-01-16 A | 15511010 FS-100d, 9-100M FS+120d | 100% | 2010-06-21 | 2012-01-13 |  |  |  | MECH ENG [160 h]; VISTNG USERS [880 h]; MECH DES [440 h] | 47,883.27 | 47,883.27 | 0 | 46413.6 | CHUDAKOV | 1 | 1 | D | H | EUGENE C | 11-006 | 11-026 |  |  |  |  |  |  |  |  |  |  |  |  |  |  |  |  |  |  |  |  |  | 09-014 |  |  |  |  |  |  |  |  | 11-030 |  |  |  |  |  |  |
| 15511030 |  | Dsgn Supprt for Vac Chamb (TAGGING Mag) | 369d | 2010-06-21 A | 2011-12-12 A | 9-100M FS+120d, 15511015 FS-120d | 100% |  |  |  |  |  | MECH DES [440 h]; VISTNG USERS [880 h]; MECH ENG [160 h] | 47,808.09 | 47,808.09 | 0 | 46413.6 | CHUDAKOV | 1 | 1 | D | H | EUGENE C | 11-006 | 11-026 |  |  |  |  |  |  |  |  |  |  |  |  |  |  |  |  |  |  |  |  |  | 09-014 |  |  |  |  |  |  |  |  | 11-030 |  |  |  |  |  |  |
| 15511040 |  | Write Pwr Supply Spec (TAGGING Mag) | 164d | 2010-06-28 A | 2011-02-28 A | 15511010 | 100% |  |  |  |  |  | ELEC TECH [200 h]; CONTRB UNIV LBR [240 h] | 8,446.15 | 8,446.15 | 0 | 8290 | CHUDAKOV | 1 | 1 | D | H | EUGENE C | 11-006 | 11-026 |  |  |  |  |  |  |  |  |  |  |  |  |  |  |  |  |  |  |  |  |  | 09-014 |  |  |  |  |  |  |  |  | 11-030 |  |  |  |  |  |  |
| 15511045 |  | EH&S Review of Dsgn before Constrctn (TAGGING Mag) | 7d | 2010-07-01 A | 2010-07-12 A | 15511030 FS-50d, 15511015 FS-50d, 15511025 FS-50d, 15511010 FS-50d | 100% |  |  |  |  |  |  |  |  |  | 0 | CHUDAKOV | 1 | 1 | D | Z | EUGENE C | 11-006 | 11-026 |  |  |  |  |  |  |  |  |  |  |  |  |  |  |  |  |  |  |  |  |  | 09-014 |  |  |  |  |  |  |  |  | 11-030 |  |  |  |  |  |  |
| 15511015 |  | Drawings for Vac Chamb (TAGGING Mag) | 286d | 2010-07-19 A | 2011-09-10 A | 9-100M FS+120d, 15511010 FS-100d | 100% | 2010-07-19 | 2011-09-09 |  |  |  | CONTRB UNIV LBR [240 h]; MECH ENG [160 h]; VISTNG USERS [880 h]; PD UNIV STUDNT [880 h]; MECH DES [440 h] | 56,666.35 | 56,666.35 | 0 | 55231.2 | CHUDAKOV | 1 | 1 | D | H | EUGENE C | 11-006 | 11-026 |  |  |  |  |  |  |  |  |  |  |  |  |  |  |  |  |  |  |  |  |  | 09-014 |  |  |  |  |  |  |  |  | 11-030 |  |  |  |  |  |  |
| 15511035 |  | Dsgn Stands for Quad (TAGGING Mag) | 48d | 2010-07-26 A | 2010-09-30 A | 9-120M | 100% |  |  |  |  |  | VISTNG USERS [880 h]; MECH DES [440 h]; MECH ENG [160 h] | 46,413.6 | 46,413.6 | 0 | 49424.4 | CHUDAKOV | 1 | 1 | D | H | EUGENE C |  | 11-026 |  |  |  | 12-021F |  |  |  |  |  |  |  |  |  |  |  |  |  |  |  |  |  | 09-014 | 11-004 |  |  |  |  |  |  |  |  |  |  |  |  |  |  |
| 15511011E |  | FY11 Travel (TAGGING Mag) | 248d | 2010-10-01 A | 2011-09-30 A | 15511010E | 100% |  |  |  |  |  | TRAVEL | 6,267.84 |  | 0 | 6267.84 | CHUDAKOV | 1 | 1 | D | E | EUGENE C | 11-006 | 11-026 |  |  |  |  |  |  |  |  |  |  |  |  |  |  |  |  |  |  |  |  |  |  |  | 100 | 100 | 07-024 |  |  |  |  |  | 8.46774193 | 91.53225806 |  |  |  |  |
| 15511100 |  | Proc Turbo Pumps (TAGGING Mag) | 558d | 2010-10-25 A | 2013-06-17 A | 9-110M | 100% | 2010-10-25 | 2013-01-30 |  |  |  | PROCUREMENT>$50K 69; PROCUREMENT<$50K 60; SKLLD TRADE [200 h] | 68,932.83 | 6,674.19 | 0 | 69202.18 | CHUDAKOV | 1 | 1 | D | D | EUGENE C |  | 11-026 | XX |  |  |  | 100 |  |  |  |  |  |  |  |  |  |  | 0 | 62298.18 | 6229818 | APP |  | 5511 |  |  |  |  |  |  |  |  |  |  |  |  |  |  |  |  |
| 15511004a |  | Engineering Support for Component Procurements FY11 (TAGGING Mag) | 170d | 2011-02-01 A | 2011-09-30 A | 9-110M FS+59d | 100% |  |  |  |  |  | MECH ENG [320 h]; MECH DES [320 h] | 36,681.6 | 36,681.6 | 0 | 36681.6 | CHUDAKOV | 1 | 1 | D | E | EUGENE C | 11-006 | 11-026 |  |  |  |  |  |  |  |  |  |  |  |  |  |  |  |  |  |  |  |  |  | 09-014 |  | 100 | 100 | 07-024 | 2 |  | 09-027 | 09-027 | 11-030 | 11.11111111 | 88.88888888 |  |  |  |  |
| 15511003 |  | Evaluate Procurements 2010 (TAGGING Mag) | 123d | 2011-02-19 A | 2011-08-15 A | 15511002 | 100% | 2011-02-22 | 2011-08-15 |  |  |  | MECH ENG [160 h]; MECH DES [40 h] | 12,739.2 | 12,739.2 | 0 | 12739.2 | CHUDAKOV | 1 | 1 | D | S | EUGENE C | 11-006 | 11-026 |  |  |  |  |  |  |  |  |  |  |  |  |  |  |  |  |  |  |  |  |  | 09-014 |  |  |  | 07-024 | 2 | ST | 09-027 | 09-027 | 11-030 |  |  |  |  |  |  |
| 15511050 |  | Vend Fab Tagger Magnet Peg Point #1 Submit Foundry reports | 154d | 2011-04-15 A | 2011-11-21 A | 15511003 FS-250d, 15511045, 9-110M FS+100d | 100% |  |  |  |  |  | PROCUREMENT<$50K 60 NO ESCALATION; PROCUREMENT>$50K 69 NO ESCALATION | 442,539.61 |  | 0 | 442539.61 | CHUDAKOV | 1 | 1 | D | P | EUGENE C | 11-006 | 11-026 |  |  |  |  | 100 |  |  |  |  |  |  |  |  |  |  | 0 | 442539.61 | 44253961 | APP | 08-016 | 5511 | 09-014 |  |  |  |  |  |  | 09-027 | 09-027 | 11-030 |  |  | 10-024 |  |  |  |
| 15511050a |  | Vend Fab Tagger Magnet Peg Point #2 Winding tooling complete, conductor received | 157d | 2011-04-15 A | 2011-11-28 A | 15511045, 15511003 FS-164d, 9-110M FS+120d | 100% |  |  |  |  |  | PROCUREMENT>$50K 69 NO ESCALATION | 45,296 |  | 0 | 45296 | CHUDAKOV | 1 | 1 | D | P | EUGENE C | 11-006 | 11-026 |  |  |  |  | 100 |  |  |  |  |  |  |  |  |  |  | 0 | 45296 | 4529600 | APP |  | 5511 |  |  |  |  |  |  |  |  |  | 11-030 |  |  | 10-024 |  |  |  |
| 15511050b |  | Vend Fab Tagger Magnet Peg Point #3 Submit machining sequence and initial ultrasonice inspection report | 229d | 2011-04-15 A | 2012-03-19 A | 15511050a FS-139d | 100% |  |  |  |  |  | PROCUREMENT>$50K 69 NO ESCALATION | 133,880.2 |  | 0 | 133880.2 | CHUDAKOV | 1 | 1 | D | P | EUGENE C |  |  |  |  |  |  | 100 |  |  |  |  |  |  |  |  |  |  | 0 | 133880.2 | 13388020 | APP |  | 5511 |  |  |  |  |  |  |  |  |  | 11-030 |  |  |  |  |  |  |
| 15511050c |  | Vend Fab Tagger Magnet Peg Point #4 Twelve coil assemblies wound | 269d | 2011-04-15 A | 2012-05-14 A | 15511050b FS-176d | 100% |  |  |  |  |  | PROCUREMENT>$50K 69 NO ESCALATION | 78,454.23 |  | 0 | 78454.23 | CHUDAKOV | 1 | 1 | D | P | EUGENE C |  |  |  |  |  |  | 100 |  |  |  |  |  |  |  |  |  |  | 0 | 78454.23 | 7845423 | APP |  | 5511 |  |  |  |  |  |  |  |  |  | 11-030 |  |  |  |  |  |  |
| 15511050d |  | Vend Fab Tagger Magnet Peg Point #5 Coil resin impregnation complete | 376d | 2011-04-15 A | 2012-10-15 A | 15511050c FS-176d | 100% |  |  |  |  |  | PROCUREMENT>$50K 69 NO ESCALATION | 102,401.33 |  | 0 | 102401.33 | CHUDAKOV | 1 | 1 | D | P | EUGENE C |  |  |  |  |  |  | 100 |  |  |  |  |  |  |  |  |  |  | 0 | 102401.33 | 10240133 | APP |  | 5511 |  |  |  |  |  |  |  |  |  | 11-030 |  |  |  |  |  |  |
| 15511050f |  | Vend Fab Tagger Magnet Peg Point #6 Submit hydrostatic pressure test, flow and pressure test data | 396d | 2011-04-15 A | 2012-11-12 A | 15511050d FS-238d | 100% |  |  |  |  |  | PROCUREMENT>$50K 69 NO ESCALATION | 5,023.33 |  | 0 | 5023.33 | CHUDAKOV | 1 | 1 | D | P | EUGENE C |  |  |  |  |  |  | 100 |  |  |  |  |  |  |  |  |  |  | 0 | 5023.33 | 502333 | APP |  | 5511 |  |  |  |  |  |  |  |  |  | 11-030 |  |  |  |  |  |  |
| 15511050g |  | Vend Fab Tagger Magnet Peg Point #7 Submit dimensional and electrical test data | 356d | 2011-04-15 A | 2012-09-17 A | 15511050f FS-259d | 100% |  |  |  |  |  | PROCUREMENT>$50K 69 NO ESCALATION | 3,892.91 |  | 0 | 3892.91 | CHUDAKOV | 1 | 1 | D | P | EUGENE C |  |  |  |  |  |  | 100 |  |  |  |  |  |  |  |  |  |  | 0 | 3892.91 | 389291 | APP |  | 5511 |  |  |  |  |  |  |  |  |  | 11-030 |  |  |  |  |  |  |
| 15511050h |  | Vend Fab Tagger Magnet Peg Point #8 Submit coil dim. and electrical inspection tests if coil manufactured outside Everso | 356d | 2011-04-15 A | 2012-09-17 A | 15511050g FS-281d | 100% |  |  |  |  |  |  |  |  |  | 0 | CHUDAKOV | 1 | 1 | D | P | EUGENE C |  |  |  |  |  |  |  |  |  |  |  |  |  |  |  |  |  |  |  |  | APP |  | 5511 |  |  |  |  |  |  |  |  |  | 11-030 |  |  |  |  |  |  |
| 15511050j |  | Vend Fab Tagger Magnet Peg Point #9 Submit dimension inspection report for core #1 and initial rep. on cores 2,3 and 4 | 356d | 2011-04-15 A | 2012-09-17 A | 15511050h FS-301d | 100% |  |  |  |  |  | PROCUREMENT>$50K 69 NO ESCALATION | 189,643.34 |  | 0 | 189643.34 | CHUDAKOV | 1 | 1 | D | P | EUGENE C |  |  |  |  |  |  | 100 |  |  |  |  |  |  |  |  |  |  | 0 | 189643.34 | 18964334 | APP |  | 5511 |  |  |  |  |  |  |  |  |  | 11-030 |  |  |  |  |  |  |
| 15511050k |  | Vend Fab Tagger Magnet Peg Point #10 Magnet assembly complete | 396d | 2011-04-15 A | 2012-11-12 A | 15511050j FS-346d | 100% |  |  |  |  |  | PROCUREMENT>$50K 69 NO ESCALATION | 89,559.87 |  | 0 | 89559.87 | CHUDAKOV | 1 | 1 | D | P | EUGENE C |  |  |  |  |  |  | 100 |  |  |  |  |  |  |  |  |  |  | 0 | 89559.87 | 8955987 | APP |  | 5511 |  |  |  |  |  |  |  |  |  | 11-030 |  |  |  |  |  |  |
| 15511050n |  | Vend Fab Tagger Magnet Peg Point #11 Magnet components arrive at JLab | 428d | 2011-04-15 A | 2013-02-11 A | 15511050k FS-365d | 100% | 2011-04-15 | 2013-01-07 |  |  |  | PROCUREMENT>$50K 69 NO ESCALATION | 13,504 |  | 0 | 13504 | CHUDAKOV | 1 | 1 | D | P | EUGENE C |  |  | XX |  |  |  | 100 |  |  |  |  |  |  |  |  |  |  | 0 | 13504 | 1350400 | APP |  | 5511 |  |  |  |  |  |  |  |  |  | 11-030 |  |  |  |  |  |  |
| 15511004 |  | Engineering Support for Magnet Acceptance 2012 (TAGGING Mag) | 50d | 2011-10-03 A | 2011-12-13 A | 9-120M | 100% |  |  |  |  |  | MECH ENG [80 h]; MECH DES [80 h] | 9,463.2 | 9,463.2 | 0 | 9463.2 | CHUDAKOV | 1 | 1 | D | E | EUGENE C | 11-006 | 11-026 |  |  |  |  |  |  |  |  |  |  |  |  |  |  |  |  |  |  |  |  |  | 09-014 |  | 100 | 100 | 07-024 | 2 |  | 09-027 | 09-027 | 11-030 | 18 | 82 |  |  |  |  |
| 15511004b |  | Engineering Support for Component Procurements FY12 (TAGGING Mag) | 228d | 2011-10-03 A | 2012-08-31 A | 15511004a | 100% |  |  |  |  |  | MECH ENG [240 h]; MECH DES [80 h] | 20,682.4 | 20,682.4 | 0 | 20682.4 | CHUDAKOV | 1 | 1 | D | E | EUGENE C | 11-006 | 11-026 |  |  |  |  |  |  |  |  |  |  |  |  |  |  |  |  |  |  |  |  |  | 09-014 |  | 100 | 100 | 07-024 | 2 |  | 09-027 | 09-027 | 11-030 | 10.08771929 | 89.9122807 |  |  |  |  |
| 15511012E |  | FY12 Travel (TAGGING Mag) | 183d | 2011-10-03 A | 2012-06-29 A | 15511011E, 9-110M | 100% |  |  |  |  |  | TRAVEL | 4,848.5 |  | 0 | 4848.5 | CHUDAKOV | 1 | 1 | D | E | EUGENE C | 11-006 | 11-026 |  |  |  |  |  |  |  |  |  |  |  |  |  |  |  |  |  |  |  |  |  |  |  | 100 | 100 | 07-024 |  |  |  |  |  | 10.92896174 | 89.07103825 |  |  |  |  |
| 15511060 |  | Proc Vac Chamb (TAGGING Mag) | 232d | 2012-02-01 A | 2013-02-11 A | 15511003 FS-164d, 15511045, 9-120M FS+60d | 100% | 2012-02-01 | 2013-01-07 |  |  |  | VISTNG USERS [120 h]; PROCUREMENT<$50K 60; PROCUREMENT>$50K 69 | 80,296.13 | 2,344.88 | 0 | 80275.93 | CHUDAKOV | 1 | 1 | D | D | EUGENE C | 11-006 | 11-026 | XX |  |  |  | 100 |  |  |  |  |  |  |  |  |  |  | 0 | 77956.33 | 7795633 | APP | 08-016 | 5511 | 09-014 |  |  |  |  |  |  | 09-027 | 09-027 | 11-030 |  |  |  |  |  |  |
| 15511065 |  | Proc Pwr Supply (TAGGING Mag) | 211d | 2012-03-02 A | 2013-06-17 A | 15511045, 15511040, 9-120M FS+100d | 100% | 2012-03-02 | 2013-01-07 |  |  |  | PROCUREMENT<$50K 60 | 41,276 |  | 0 | 41276 | CHUDAKOV | 1 | 1 | D | D | EUGENE C | 11-006 | 11-026 | XX |  |  |  | 100 |  |  |  |  |  |  |  |  |  |  | 0 | 41276 | 4127600 | APP | 08-016 | 5511 | 09-014 |  |  |  |  |  |  |  |  | 11-030 |  |  |  |  |  |  |
| 15511110 |  | Proc. Tagger magnet stands | 97d | 2012-05-01 A | 2012-09-17 A | 9-120M FS+121d | 100% |  |  |  |  |  | PROCUREMENT<$50K 60 | 17,500 |  | 0 | 17500 | CHUDAKOV | 1 | 1 | D | D | EUGENE C |  | 11-026 |  |  |  | 12-021 | 100 |  |  |  |  |  |  |  |  |  |  | 0 | 17500 | 1750000 | APP |  | 5511 |  |  |  |  |  |  |  |  |  |  |  |  |  |  |  |  |
| 15511071 |  | Proc Quad Power Supply (TAGGING Mag) | 148d | 2012-06-03 A | 2013-06-17 A | 9-120M FS+184d, 15511070 | 100% | 2012-06-05 | 2013-01-09 |  |  |  | PROCUREMENT<$50K 60 | 5,493.93 |  | 0 | 5493.93 | CHUDAKOV | 1 | 1 | D | D | EUGENE C | 11-006 | 11-026 | XX |  |  | 12-021F | 100 |  |  |  |  |  |  |  |  |  |  | 0 | 5493.93 | 549393 | APP | 08-016 | 5511 | 09-014 | 11-004 |  |  |  |  |  |  |  |  |  |  |  | 15511071 |  |  |
| 15511095 |  | Proc, calibrate, Install NMR (TAGGING Mag) FY12 | 184d | 2012-07-02 A | 2013-03-11 A | 15511015, 9-120M | 100% | 2012-07-02 | 2013-03-29 |  |  |  | MECH DES [88.29 h]; MECH ENG [29.43 h]; MECH TECH [29.43 h]; PD UNIV STUDNT [647.43 h] | 14,834.98 | 14,821.66 | 0 | 14532.5082 | CHUDAKOV | 1 | 1 | D | S | EUGENE C | 11-006 | 11-026 |  |  |  | 12-021 |  |  |  |  |  |  |  |  |  |  |  |  |  |  | APP |  | 5511 | 09-014 |  |  |  |  |  | ST |  |  |  |  |  |  | 15511071 | 12-053 |  |
| 15511095a |  | Proc, calibrate, Install NMR (TAGGING Mag) FY13 | 184d | 2012-07-02 A | 2013-03-11 A | 15511095 FS-145d | 100% | 2012-07-02 | 2013-03-29 |  |  |  | MECH ENG [18.57 h]; MECH TECH [18.57 h]; PD UNIV STUDNT [408.57 h]; MECH DES [55.71 h] | 9,361.25 | 9,352.87 | 0 | 9463.0452 | CHUDAKOV | 1 | 1 | D | S | EUGENE C | 11-006 | 11-026 |  |  |  | 12-021 |  |  |  |  |  |  |  |  |  |  |  |  |  |  | APP |  | 5511 | 09-014 |  |  |  |  |  | ST |  |  |  |  |  |  | 15511071 | 12-053 |  |
| 15511095b |  | Proc, calibrate, Install NMR (TAGGING Mag) Procurement | 184d | 2012-07-02 A | 2013-08-30 A | 9-120M, 15511015 | 100% | 2012-07-02 | 2013-03-29 |  |  |  | PROCUREMENT<$50K 60 NO ESCALATION FY13 | 37,778.32 |  | 7555.664 | 37778.32 | CHUDAKOV | 1 | 1 | D | S | EUGENE C | 11-006 | 11-026 |  |  |  | 12-021 | 100 |  |  |  |  |  |  |  |  |  |  | 0 | 37778.32 | 3777832 | APP |  | 5511 | 09-014 |  |  |  |  |  | ST |  |  |  |  |  |  |  | 12-053 |  |
| 15511105 |  | Tagger Magnet Acceptance Test (TAGGING Mag) | 1d | 2013-01-07 A | 2013-01-21 A | 15511004 FS-50d, 15511065 FS-15d, 15511050n, 15511060, 15511004b FS-50d, 15511050, 15511050a | 100% | 2013-08-26 | 2013-08-26 |  |  |  |  |  |  |  | 0 | CHUDAKOV | 1 | 1 | D | H | EUGENE C | 11-006 | 11-026 |  |  |  |  |  |  |  |  |  |  |  |  |  |  |  |  |  |  |  |  |  | 09-014 |  |  |  |  |  |  | 09-027 | 09-027 | 11-030 |  |  |  |  |  |  |
| 15511115 |  | Proc. Tagger beamline stands | 75d | 2013-02-04 A | 2013-07-15 A | 9-130M | 100% | 2013-03-18 | 2013-07-01 |  |  |  | PROCUREMENT<$50K 60 | 14,446.6 |  | 1444.66 | 14446.6 | CHUDAKOV | 1 | 1 | D | D | EUGENE C |  | 11-026 |  |  |  | 12-021 | 100 |  |  |  |  | 12-054F |  |  |  |  |  | 0 | 14446.6 | 1444660 | APP |  | 5511 |  |  |  |  |  |  |  |  |  |  |  |  |  |  |  |  |
| 15511120 |  | Re-Baseline Actuals Adjustment | 1d | 2013-08-30 A | 2013-08-30 A |  | 100% | 2013-09-03 | 2013-09-03 |  |  |  | PROCUREMENT>$50K 69 NO ESCALATION | 165,011.94 |  |  | 165011.94 |  |  |  |  |  |  |  |  |  |  |  |  | 100 | ADJ |  |  |  |  |  |  |  |  |  | 0 | 165011.94 | 16501194 |  |  |  |  |  |  |  |  |  |  |  |  |  |  |  |  |  |  |  |
| 25511095 |  | Proc,Calibrate, Install NMR (TAGGING Mag) FY13 | 20d | 2013-11-01 | 2013-12-02 | 9-140M, 9-130M FS+228d |  |  |  | 133d | 0d | 8/5 M-F w/JLAB Holidays ReBaseline | MECH ENG [20.65 h]; SCIENTIST [41.29 h]; SUPPLIES & MATERIALS; MECH TECH [41.29 h] | 10,316.04 |  |  | 0 | CHUDAKOV | 1 | 1 | D | S | EUGENE C | 11-006 | 11-026 |  |  |  | 12-021 |  |  | 25511095 |  |  |  | EJ | 13-015 | PR |  |  |  |  |  | APP |  | 5511 | 09-014 |  |  |  |  |  | ST |  |  |  |  |  |  |  | 12-053 | EJ |
| 25511095a |  | Proc, calibrate, Install NMR (TAGGING Mag) FY14 | 11d | 2013-12-03 | 2013-12-17 | 25511095 |  |  |  | 133d | 9d | 8/5 M-F w/JLAB Holidays ReBaseline | MECH ENG [11.35 h]; SCIENTIST [22.71 h]; SUPPLIES & MATERIALS; MECH TECH [22.71 h] | 5,738.6 |  |  | 0 | CHUDAKOV | 1 | 1 | D | S | EUGENE C | 11-006 | 11-026 |  |  |  | 12-021 |  |  | 25511095 |  |  |  | EJ | 13-015 | PR | 14-001 |  |  |  |  | APP |  | 5511 | 09-014 |  |  |  |  |  | ST |  |  |  |  |  |  |  | 12-053 | EJ |

Notes:
- 15511002: Steps: Complete Magnet Steel SOW (done); Complete Coil SOW (done); Complete Vacuum Chamber SOW (done); Complete Magnetic Field Analysis (done); Complete Structural Analysis (done)
- 15511003: Steps: Evaluate Magnet Steel Bids (done); Evaluate Coil Fab Bids (done); Evaluate Vacuum Chamber Fab Bids (done); Evaluate Stand Fab Bids (done)
- 15511095: Steps: Write PR (done); Receive components (done); Test NMR (done); Install NMR (done); Verify NMR operation (done)
- 15511095a: Steps: Write PR (done); Receive components (done); Test NMR (done); Install NMR (done); Verify NMR operation (done)
- 15511095b: Steps: Write PR (done); Receive components (done); Test NMR (done); Install NMR (done); Verify NMR operation (done)
- 25511095: Steps: Proc,Calibrate, Install NMR (TAGGING Mag) FY13
- 25511095a: Steps: Proc,Calibrate, Install NMR (TAGGING Mag) FY14

| ID | WBS | Activity | Duration | Start | Finish | Predecessors | Complete | Remaining | Planned start | Planned finish | Total float | Free float | Calendar | Resources | Cost | Actual cost | LOE % Pre Calc | LOE % | LOE Divider | LOE Multiplier | Calculated Remaining Total Cost | MONTHLY EV COST | RESP - Responsibility | STRT%COMP for CM EVM | FNSH%COMP for CM EVM | 12 GeV 2nd level Critical Path | HALL D Related Milestones | CR 07-024 | EVMS Reporting Codes | CAM RESPONSIBLE | CR 09-014 | CR 09-027 | CR 09-027 Repair | CR 11-006 | CR 11-026 | CR 12-034 | MARCH!!! | Remaining Material Cost Based on % Compl | Claimed Material Cost Based on % Complet | Initial Claimed Material Calc | Claimed Material Divider | CR 08-016 | CR 09-012 | CR 12-021 | Profile change | CR 12-055 | Specification | CR 12-054 | Activities with Steps | ReBaseline Actuals Adjustment | Pre Rebaseline Remaining Budget | Original Activity ID Rebaseline | CR 13-007 | BOE Labor | CR 13-015 | Previously In Progress | Post Rebaseline | PRIOR MONTH EV COST | BOE Procurement | Obligated Prior to Rebaseline | CR 14-001 | BOE Expenses |
| --- | --- | --- | --- | --- | --- | --- | --- | --- | --- | --- | --- | --- | --- | --- | --- | --- | --- | --- | --- | --- | --- | --- | --- | --- | --- | --- | --- | --- | --- | --- | --- | --- | --- | --- | --- | --- | --- | --- | --- | --- | --- | --- | --- | --- | --- | --- | --- | --- | --- | --- | --- | --- | --- | --- | --- | --- | --- | --- | --- | --- | --- | --- |
|  | 2 | **1.5.5.1.2 HODOSCOPE** |  | 2011-10-03 | 2014-04-01 |  |  |  |  |  |  |  |  |  |  |  |  |  |  |  |  |  |  |  |  |  |  |  |  |  |  |  |  |  |  |  |  |  |  |  |  |  |  |  |  |  |  |  |  |  |  |  |  |  |  |  |  |  |  |  |  |  |
| 15512004 |  | Prepare Procurement/Fabrication Packages 2012(HODOSCP) | 247d | 2011-10-03 A | 2012-09-28 A | 9-120M | 100% |  |  |  |  |  |  | MECH ENG [160 h]; MECH DES [320 h] | 26,633.6 | 26,633.6 | 7.69230769 | 92.3076923 | 100 | 100 | 0 | 26633.6 | CHUDAKOV | 1 | 1 | 2 | D | 07-024 | E | EUGENE C | 09-014 | 09-027 | 09-027 | 11-006 | 11-026 |  |  |  |  |  |  |  |  |  |  |  |  |  |  |  |  |  |  |  |  |  |  |  |  |  |  |  |
| 15512012E |  | FY12 Travel (HODOSCP) | 247d | 2011-10-03 A | 2012-09-28 A | 9-120M | 100% |  |  |  |  |  |  | TRAVEL | 884.52 |  | 7.69230769 | 92.3076923 | 100 | 100 | 0 | 884.52 | CHUDAKOV | 1 | 1 |  | D | 07-024 | E | EUGENE C |  | 09-027 | 09-027 | 11-006 | 11-026 |  |  |  |  |  |  |  |  |  |  |  |  |  |  |  |  |  |  |  |  |  |  |  |  |  |  |  |
| 15512136 |  | Design & Layout Preamp Cards (HODOSCP) | 304d | 2011-10-03 A | 2013-01-31 A | 12351055M, 9-120M | 100% |  | 2011-10-03 | 2012-12-20 |  |  |  | CONTRB UNIV LBR [1280 h] |  |  |  |  |  |  |  | 0 | CHUDAKOV | 1 | 1 |  | D |  | Z | EUGENE C |  |  |  | 11-006 | 11-026 | 12-034F | XX |  |  |  |  |  |  |  |  |  |  |  |  |  |  |  |  |  |  |  |  |  |  |  |  |  |
| 15512001 |  | Prepare Procurements for Thin Window Test 2011 (HODOSCP) | 65d | 2011-10-05 A | 2012-01-16 A | 9-120M | 100% |  | 2011-10-05 | 2012-01-13 |  |  |  | MECH ENG [160 h]; MECH DES [80 h] | 15,072.8 | 15,072.8 |  |  |  |  | 0 | 15072.8 | CHUDAKOV | 1 | 1 | 2 | D | 07-024 | H | EUGENE C | 09-014 | 09-027 | 09-027 | 11-006 | 11-026 |  |  |  |  |  |  |  |  |  |  |  |  |  |  |  |  |  |  |  |  |  |  |  |  |  |  |  |
| 15512020 |  | AL Foil for Thin Window (HODOSCP) | 25d | 2012-01-09 A | 2012-02-13 A | 9-120M FS+60d | 100% |  |  |  |  |  |  | PROCUREMENT<$50K 60 | 1,614.61 |  |  |  |  |  | 0 | 1614.61 | CHUDAKOV | 1 | 1 |  | D | 07-024 | H | EUGENE C |  |  |  | 11-006 | 11-026 |  |  | 0 | 1614.61 | 161461 | 100 |  |  |  |  |  |  |  |  |  |  |  |  |  |  |  |  |  |  |  |  |  |
| 15512025 |  | Frame & Vacuum System for Limit Test of Thin Window (HODOSCP) | 64d | 2012-01-16 A | 2012-04-16 A | 15512020 FS-50d, 15512001 | 100% |  | 2012-01-17 | 2012-04-16 |  |  |  | PROCUREMENT<$50K 60 NO ESCALATION FY13 | 23,400.11 |  |  |  |  |  | 0 | 23400.11 | CHUDAKOV | 1 | 1 |  | D | 07-024 | H | EUGENE C |  | 09-027 | 09-027 | 11-006 | 11-026 |  |  | 0 | 23400.11 | 2340011 | 100 | 08-016 | 09-012 |  |  |  |  |  |  |  |  |  |  |  |  |  |  |  |  |  |  |  |
| 15512002 |  | Engineering Support for Testing Thin Window (HODOSCP) | 73d | 2012-02-01 A | 2012-05-14 A | 9-130M FS-180d | 100% |  |  |  |  |  |  | MECH ENG [160 h]; MECH DES [320 h] | 26,633.6 | 26,633.6 |  |  |  |  | 0 | 27484.8 | CHUDAKOV | 1 | 1 | 2 | D | 07-024 | H | EUGENE C | 09-014 | 09-027 | 09-027 | 11-006 | 11-026 |  |  |  |  |  |  |  |  |  |  |  |  |  |  |  |  |  |  |  |  |  |  |  |  |  |  |  |
| 15512030 |  | Test Window to limit (HODOSCP) | 53d | 2012-02-01 A | 2012-04-16 A | 15512002 FS-225d, 15512025 FS-180d | 100% |  |  |  |  |  |  | MECH TECH [440 h]; CONTRB UNIV LBR [1200 h] | 19,553.6 | 19,553.6 |  |  |  |  | 0 | 20178.4 | CHUDAKOV | 1 | 1 |  | D |  | H | EUGENE C |  | 09-027 | 09-027 | 11-006 | 11-026 |  |  |  |  |  |  |  |  |  |  |  |  |  |  |  |  |  |  |  |  |  |  |  |  |  |  |  |
| 15512170 |  | Purchase Power Supply for DAC Chips (HODOSCP) | 13d | 2012-02-01 A | 2012-02-20 A | 9-120M FS+60d | 100% |  | 2012-02-01 | 2012-02-17 |  |  |  | PROCUREMENT<$50K 60 | 2,380.95 |  |  |  |  |  | 0 | 2380.95 | CHUDAKOV | 1 | 1 |  | D |  | H | EUGENE C |  |  |  | 11-006 | 11-026 | 12-034F |  | 0 | 2380.95 | 238095 | 100 |  |  |  |  |  |  |  |  |  |  |  |  |  |  |  |  |  |  |  |  |  |
| 15512100 |  | Proc Fibers for Microscope (HODOSCP) | 55d | 2012-07-02 A | 2012-09-17 A | 12351055M, 9-120M FS+184d | 100% |  |  |  |  |  |  | PROCUREMENT>$50K 69 | 12,285.06 |  |  |  |  |  | 0 | 12285.06 | CHUDAKOV | 1 | 1 |  | D |  | H | EUGENE C |  |  |  | 11-006 | 11-026 | 12-034F |  | 0 | 12285.06 | 1228506 | 100 |  |  | 12-021 |  |  |  |  |  |  |  |  |  |  |  |  |  |  |  |  |  |  |
| 15512110 |  | Proc SiPMs for Microscope (HODOSCP) Part A | 163d | 2012-07-02 A | 2013-04-15 A | 9-120M FS+190d | 100% |  | 2012-07-02 | 2013-02-28 |  |  |  | PROCUREMENT<$50K 60 NO ESCALATION FY13 | 42,400.71 |  |  |  |  |  | 0 | 42400.71 | CHUDAKOV | 1 | 1 |  | D |  | D | EUGENE C |  |  |  | 11-006 | 11-026 | 12-034 | XX | 0 | 42400.71 | 4240071 | 100 |  |  | 12-021 | C | 12-055 |  |  |  |  |  |  |  |  |  |  |  |  |  |  |  |  |
| 15512013E |  | FY13 Travel (HODOSCP) | 248d | 2012-10-01 A | 2013-08-30 A | 15512012E, 15511012E | 100% |  | 2012-10-01 | 2013-09-30 |  |  |  | TRAVEL | 839.13 |  | 8.06451612 | 91.93548387 | 100 | 100 | 154.618156 | 839.13 | CHUDAKOV | 1 | 1 |  | D | 07-024 | E | EUGENE C |  |  |  | 11-006 | 11-026 |  |  |  |  |  |  |  |  |  |  |  |  |  |  |  |  |  |  |  |  |  |  |  |  |  |  |  |
| 15512003 |  | Prepare Procurement/Fabrication Packages 2013 (HODOSCP) | 25d | 2012-12-03 A | 2013-01-14 A | 15512004, 9-130M FS+43d | 100% |  | 2013-01-02 | 2013-02-06 |  |  |  | MECH ENG [120 h]; MECH DES [320 h] | 24,590.4 | 24,590.4 | 36 | 64 | 100 | 100 | 0 | 24590.4 | CHUDAKOV | 1 | 1 | 2 | D | 07-024 | E | EUGENE C | 09-014 | 09-027 | 09-027 | 11-006 | 11-026 |  | XX |  |  |  |  |  |  |  |  |  |  |  |  |  |  |  |  |  |  |  |  |  |  |  |  |  |
| 15512035 |  | Fab Final Thin Exit Window & AL Flange (HODOSCP) | 45d | 2012-12-03 A | 2013-08-30 A | 15512030, 15512003 | 100% |  | 2013-01-15 | 2013-03-20 |  |  |  | PROCUREMENT<$50K 60 | 24,146.57 |  |  |  |  |  | 12073.285 | 24146.57 | CHUDAKOV | 1 | 1 |  | D | 07-024 | D | EUGENE C |  | 09-027 | 09-027 | 11-006 | 11-026 |  |  | 0 | 24146.57 | 2414657 | 100 |  |  |  |  |  | 15512035 |  |  |  |  |  |  |  |  |  |  |  |  |  |  |  |
| 15512120 |  | Proc Cables for Microscope (HODOSCP) | 65d | 2013-02-04 A | 2013-02-18 A | 9-120M FS+163d, 9-130M FS+110d, 12351055M | 100% |  | 2013-03-18 | 2013-06-17 |  |  |  | PROCUREMENT>$50K 69 | 912.6 |  |  |  |  |  | 0 | 912.6 | CHUDAKOV | 1 | 1 |  | D |  | H | EUGENE C |  |  |  | 11-006 | 11-026 | 12-034F |  | 0 | 912.6 | 91260 | 100 |  |  | 12-021 |  |  |  |  |  |  |  |  |  |  |  |  |  |  |  |  |  |  |
| 15512010 |  | Catholic University Tagger Hodoscope Fixed Array | 160d | 2013-02-11 A | 2013-08-30 A | 15512005a FS-250d, 9-130M | 100% |  | 2013-03-01 | 2013-10-15 |  |  |  | PROCUREMENT<$50K 60 NO ESCALATION FY14; PROCUREMENT>$50K 69 NO ESCALATION FY14 | 73,399.23 |  |  |  |  |  | 73399.23 | 0 | CHUDAKOV | 1 | 1 |  | D |  | D | EUGENE C |  |  |  | 11-006 | 11-026 | 12-034 |  | 0 | 73399.23 | 7339923 | 100 |  |  | 12-021 |  |  |  | 12-054 |  |  |  |  |  |  |  |  |  |  |  |  |  |  |
| 15512050 |  | Proc PMTs for Fixed Array (HODOSCP) | 142d | 2013-02-11 A | 2013-05-13 A | 9-120M FS+184d, 9-130M | 100% |  | 2013-03-18 | 2013-10-04 |  |  |  | PROCUREMENT>$50K 69 | 54,933.48 |  |  |  |  |  | 0 | 54933.48 | CHUDAKOV | 1 | 1 |  | D | 07-024 | D | EUGENE C |  |  |  | 11-006 | 11-026 | 12-034 |  | 0 | 54933.48 | 5493348 | 100 |  |  | 12-021 |  |  |  |  |  |  |  |  |  |  |  |  |  |  |  |  |  |  |
| 15512055 |  | Proc Dividers for Fixed Array (HODOSCP) | 142d | 2013-02-11 A | 2013-08-30 A | 9-130M, 9-120M FS+184d | 100% |  | 2013-03-18 | 2013-10-04 |  |  |  | PROCUREMENT>$50K 69 | 32,622.03 |  |  |  |  |  | 32622.03 | 32622.03 | CHUDAKOV | 1 | 1 |  | D | 07-024 | D | EUGENE C |  |  |  | 11-006 | 11-026 | 12-034 |  | 0 | 32622.03 | 3262203 | 100 |  |  | 12-021 |  |  |  |  |  |  |  |  |  |  |  |  |  |  |  |  |  |  |
| 15512005 |  | Design Hodoscope Supprt (HODOSCP) | 59d | 2013-04-01 A | 2013-08-30 A | 9-130M FS+110d, 9-120M FS+188d | 100% |  | 2013-05-01 | 2013-07-24 |  |  |  | MECH DES [440 h]; MECH TECH [320 h]; PD UNIV STUDNT [640 h] | 43,594 | 43,594 |  |  |  |  | 25346.64 | 42244.4 | CHUDAKOV | 1 | 1 |  | D |  | S | EUGENE C |  |  |  | 11-006 | 11-026 | 12-034F |  |  |  |  |  |  |  | 12-021 |  |  | 15512005 | 12-054F | ST |  |  |  |  |  |  |  |  |  |  |  |  |  |
| 15512005a |  | Construct Hodoscope Supprt (HODOSCP) | 52d | 2013-04-08 A | 2013-08-30 A | 15512005 FS-80d | 100% |  | 2013-11-22 | 2014-02-14 |  |  |  | PROCUREMENT<$50K 60 | 23,424.13 |  |  |  |  |  | 20613.2344 | 23424.13 | CHUDAKOV | 1 | 1 |  | D |  | D | EUGENE C |  |  |  | 11-006 | 11-026 | 12-034F |  | 0 | 23424.13 | 2342413 | 100 |  |  | 12-021 |  |  | 15512005 | 12-054 |  |  |  |  |  |  |  |  |  |  |  |  |  |  |
| 15512110a |  | Proc SiPM support Equipment for Microscope (HODOSCP) Part B | 76d | 2013-07-01 A | 2013-07-15 A | 9-130M FS+110d, 9-120M FS+190d | 100% |  | 2013-08-01 | 2013-11-15 |  |  |  | PROCUREMENT>$50K 69 NO ESCALATION FY13; PROCUREMENT<$50K 60 NO ESCALATION FY13 | 98,000 |  |  |  |  |  | 98000 | 98000 | CHUDAKOV | 1 | 1 |  | D |  | D | EUGENE C |  |  |  | 11-006 | 11-026 | 12-034 |  | 0 | 98000 | 9800000 | 100 |  |  | 12-021 | C | 12-055 |  |  |  |  |  |  |  |  |  |  |  |  |  |  |  |  |
| 15512175 |  | Re-Baseline Actuals Adjustment | 1d | 2013-08-30 A | 2013-08-30 A |  | 100% |  | 2013-09-03 | 2013-09-03 |  |  |  | PROCUREMENT>$50K 69 NO ESCALATION | -119,497.81 |  |  |  |  |  |  |  |  |  |  |  |  |  |  |  |  |  |  |  |  |  |  |  |  |  | 100 |  |  |  |  |  |  |  |  | ADJ |  |  |  |  |  |  |  |  |  |  |  |  |
| 25512005 |  | Design Hodoscope Supprt (HODOSCP) FY13 | 31d | 2013-09-03 A | 2013-11-15 | 9-130M FS+228d |  | 11d | 2013-10-01 | 2013-11-12 | 148d | 1d | 8/5 M-F w/JLAB Holidays ReBaseline | MECH DES [22.58 h]; MECH ENG [29.03 h] | 3,326.04 | 2,079.4 |  |  |  |  |  | 0 | CHUDAKOV | 1 | 1 |  | D |  | S | EUGENE C |  |  |  | 11-006 | 11-026 | 12-034F |  |  |  |  |  |  |  | 12-021 |  |  |  | 12-054F | ST |  | 42244.4 | 25512005 | 13-007F | PE | 13-015 | Review | PR |  |  |  |  |  |
| 25512005a |  | Construct Hodoscope Supprt (HODOSCP) Part A | 30d | 2013-09-03 A | 2013-11-25 | 25512005 FS-12d, 25512005b FS-12d | 70% | 17d | 2013-11-12 | 2014-01-06 | 147d | 80d | 8/5 M-F w/JLAB Holidays ReBaseline | PROCUREMENT<$50K 60 | 24,171.36 |  |  |  |  |  |  | 15711.384 | CHUDAKOV | 1 | 1 |  | D |  | D | EUGENE C |  |  |  | 11-006 | 11-026 | 12-034F |  | 7251.408 | 16919.952 | 1691995.2 | 100 |  |  | 12-021 |  |  |  | 12-054 |  |  |  | 25512005a | 13-007 |  | 13-015 |  | PR | 1208.568 | EJ | OB-2 | 14-001 |  |
| 25512005b |  | Design Hodoscope Supprt (HODOSCP) FY14 | 11d | 2013-09-03 A | 2013-11-15 | 25512005 FS-15d |  | 11d | 2013-10-01 | 2013-10-15 | 148d | 1d | 8/5 M-F w/JLAB Holidays ReBaseline | MECH DES [12.42 h]; MECH ENG [15.97 h] | 1,829.61 | 1,143.85 |  |  |  |  |  | 0 | CHUDAKOV | 1 | 1 |  | D |  | S | EUGENE C |  |  |  | 11-006 | 11-026 | 12-034F |  |  |  |  |  |  |  | 12-021 |  |  |  | 12-054F | ST |  | 42244.4 | 25512005 | 13-007F | PE | 13-015 | Review | PR |  |  |  | 14-001 |  |
| 25512010 |  | Catholic University Tagger Hodoscope Fixed Array | 140d | 2013-09-03 A | 2014-04-01 | 9-130M FS+228d | 15% | 97d | 2013-10-01 | 2014-04-29 | 67d | 0d | 8/5 M-F w/JLAB Holidays ReBaseline | PROCUREMENT<$50K 60 NO ESCALATION FY14 | 45,007 |  |  |  |  |  |  | 6751.05 | CHUDAKOV | 1 | 1 |  | D |  | D | EUGENE C |  |  |  | 11-006 | 11-026 | 12-034 |  | 38255.95 | 6751.05 | 675105 | 100 |  |  | 12-021 |  |  |  | 12-054 |  |  |  | 25512010 | 13-007 |  | 13-015 |  | PR |  | OB | OB |  |  |
| 25512010a |  | Catholic University Tagger Hodoscope Fixed Array Oversight FY13 | 118d | 2013-09-03 A | 2013-09-30 A | 9-130M FS+228d | 100% |  | 2013-10-01 | 2014-03-28 |  |  | 8/5 M-F w/JLAB Holidays ReBaseline | MECH ENG [1.62 h] | 120.97 | 120.56 | 63.55932203 | 36.44067796 | 100 | 100 |  | 97.7641488 | CHUDAKOV | 1 | 1 |  | D |  | E | EUGENE C |  |  |  | 11-006 | 11-026 | 12-034 |  |  |  |  |  |  |  | 12-021 |  |  |  | 12-054 |  |  |  | 25512010a | 13-007 | EJ | 13-015 |  | PR | 19.4590512 |  |  |  |  |
| 25512013LOE |  | FY13 Travel (HODOSCP) | 20d | 2013-09-03 A | 2013-09-30 A | 9-130M FS+228d | 100% |  | 2013-10-01 | 2013-10-28 |  |  | 8/5 M-F w/JLAB Holidays ReBaseline | TRAVEL | 245.32 |  |  |  | 100 | 100 |  | 0 | CHUDAKOV | 1 | 1 |  | D | 07-024 | E | EUGENE C |  |  |  | 11-006 | 11-026 |  |  |  |  |  |  |  |  |  |  |  |  |  |  |  |  | 25512013LOE |  |  | 13-015 |  | PR | 245.32 |  |  |  | PE |
| 25512056 |  | Manufacturing Drawings for Hodoscope mag shield (HODOSCP) | 20d | 2013-09-03 A | 2013-12-02 | 9-130M FS+228d | 80% | 20d | 2013-10-01 | 2013-10-28 | 107d | 0d | 8/5 M-F w/JLAB Holidays ReBaseline | MECH DES [19.2 h]; MECH ENG [9.6 h] | 1,701.79 | 824.55 |  |  |  |  |  | 527.70816 | CHUDAKOV | 1 | 1 |  | D | 07-024 | S | EUGENE C |  |  |  | 11-006 | 11-026 | 12-034 |  |  |  |  |  |  |  | 12-021 |  |  |  |  | ST |  |  | 25512056 | 13-007 | PE | 13-015 |  | PR | 791.56224 |  |  |  |  |
| 25512131 |  | UConn TAGM Contract - Procurement of Supplies for Construction | 20d | 2013-09-03 A | 2013-10-21 A | 9-130M FS+228d | 100% |  | 2013-10-01 | 2013-10-28 |  |  | 8/5 M-F w/JLAB Holidays ReBaseline | PROCUREMENT<$50K 60 NO ESCALATION | 3,500 |  |  |  |  |  |  | 3500 | CHUDAKOV | 1 | 1 |  | D |  | D | EUGENE C |  |  |  | 11-006 | 11-026 | 12-034 |  | 0 | 3500 | 350000 | 100 |  |  | 12-021 |  |  |  |  |  |  |  | 25512131 |  |  | 13-015 |  | PR |  | OB | OB |  |  |
| 25512136 |  | UConn TAGM Contract - Production 1st Article Opt Fib Bundle | 20d | 2013-09-03 A | 2013-11-27 | 25512131 FS-20d |  | 19d | 2013-10-01 | 2013-10-28 | 305d | 1d | 8/5 M-F w/JLAB Holidays ReBaseline | PROCUREMENT<$50K 60 NO ESCALATION | 3,329.1 |  |  |  |  |  |  | 0 | CHUDAKOV | 1 | 1 |  | D |  | D | EUGENE C |  |  |  | 11-006 | 11-026 | 12-034 |  | 3329.1 | 0 | 0 | 100 |  |  | 12-021 |  |  |  |  |  |  |  | 25512136 |  |  | 13-015 |  | PR |  | OB | OB |  |  |
| 25512146 |  | UConn TAGM Contract - Complete Construction of TAGM Enclosure | 62d | 2013-09-03 A | 2013-11-27 | 25512136 FS-20d |  | 19d | 2013-10-01 | 2014-01-08 | 304d | 43d | 8/5 M-F w/JLAB Holidays ReBaseline | PROCUREMENT<$50K 60 NO ESCALATION | 3,446.8 |  |  |  |  |  |  | 0 | CHUDAKOV | 1 | 1 |  | D |  | D | EUGENE C |  |  |  | 11-006 | 11-026 | 12-034 |  | 3446.8 | 0 | 0 | 100 |  |  | 12-021 |  |  |  |  |  |  |  | 25512146 |  |  | 13-015 |  | PR |  | OB | OB |  |  |
| 25512151 |  | UConn TAGM Contract - Testing of TAGM Electronic Boards | 20d | 2013-09-03 A | 2013-12-02 | 25512146 FS-62d |  | 20d | 2013-10-01 | 2013-10-28 | 261d | 0d | 8/5 M-F w/JLAB Holidays ReBaseline | PROCUREMENT<$50K 60 NO ESCALATION | 2,017.2 |  |  |  |  |  |  | 0 | CHUDAKOV | 1 | 1 |  | D |  | D | EUGENE C |  |  |  | 11-006 | 11-026 | 12-034 |  | 2017.2 | 0 | 0 | 100 |  |  | 12-021 |  |  |  |  |  |  |  | 25512151 |  |  | 13-015 |  | PR |  | OB | OB |  |  |
| 25512156 |  | UConn TAGM Contract - Complete 20 Optical Fiber Bundles | 77d | 2013-09-03 A | 2013-12-20 | 25512151 FS-20d |  | 34d | 2013-10-01 | 2014-01-30 | 261d | 43d | 8/5 M-F w/JLAB Holidays ReBaseline | PROCUREMENT<$50K 60 NO ESCALATION; PROCUREMENT>$50K 69 NO ESCALATION | 28,938.47 |  |  |  |  |  |  | 0 | CHUDAKOV | 1 | 1 |  | D |  | D | EUGENE C |  |  |  | 11-006 | 11-026 | 12-034 |  | 28938.47 | 0 | 0 | 100 |  |  | 12-021 |  |  |  |  |  |  |  | 25512156 |  |  | 13-015 |  | PR |  | OB | OB |  |  |
| 25512161 |  | UConn TAGM Contract - Complete Construction of Fiber Array Enclosure | 77d | 2013-09-03 A | 2013-12-20 | 25512156 FS-77d |  | 34d | 2013-10-01 | 2014-01-30 | 218d | 43d | 8/5 M-F w/JLAB Holidays ReBaseline | PROCUREMENT>$50K 69 NO ESCALATION | 3,571.6 |  |  |  |  |  |  | 0 | CHUDAKOV | 1 | 1 |  | D |  | D | EUGENE C |  |  |  | 11-006 | 11-026 | 12-034 |  | 3571.6 | 0 | 0 | 100 |  |  | 12-021 |  |  |  |  |  |  |  | 25512161 |  |  | 13-015 |  | PR |  | OB | OB |  |  |
| 25512166 |  | UConn TAGM Contract - Complete Assembly of Full Enclosure at UConn | 98d | 2013-09-03 A | 2014-01-31 | 25512161 FS-77d |  | 55d | 2013-10-01 | 2014-02-28 | 175d | 43d | 8/5 M-F w/JLAB Holidays ReBaseline | PROCUREMENT>$50K 69 NO ESCALATION | 3,782.2 |  |  |  |  |  |  | 0 | CHUDAKOV | 1 | 1 |  | D |  | D | EUGENE C |  |  |  | 11-006 | 11-026 | 12-034 |  | 3782.2 | 0 | 0 | 100 |  |  | 12-021 |  |  |  |  |  |  |  | 25512166 |  |  | 13-015 |  | PR |  | OB | OB |  |  |
| 25512171 |  | UConn TAGM Contract - Disassemble TAGM and Prepare for Shipment to JLab | 118d | 2013-09-03 A | 2014-02-28 | 25512166 FS-98d |  | 75d | 2013-10-01 | 2014-03-28 | 132d | 43d | 8/5 M-F w/JLAB Holidays ReBaseline | PROCUREMENT>$50K 69 NO ESCALATION | 2,627.4 |  |  |  |  |  |  | 0 | CHUDAKOV | 1 | 1 |  | D |  | D | EUGENE C |  |  |  | 11-006 | 11-026 | 12-034 |  | 2627.4 | 0 | 0 | 100 |  |  | 12-021 |  |  |  |  |  |  |  | 25512171 |  |  | 13-015 |  | PR |  | OB | OB |  |  |
| 25512176 |  | UConn TAGM Contract - TAGM Delivered to JLab | 118d | 2013-09-03 A | 2014-02-28 | 25512171 FS-118d |  | 75d | 2013-10-01 | 2014-03-28 | 89d | 22d | 8/5 M-F w/JLAB Holidays ReBaseline | PROCUREMENT>$50K 69 NO ESCALATION | 2,627.4 |  |  |  |  |  |  | 0 | CHUDAKOV | 1 | 1 |  | D |  | D | EUGENE C |  |  |  | 11-006 | 11-026 | 12-034 |  | 2627.4 | 0 | 0 | 100 |  |  | 12-021 |  |  |  |  |  |  |  | 25512176 |  |  | 13-015 |  | PR |  | OB | OB |  |  |
| 25512010aa |  | Catholic University Tagger Hodoscope Fixed Array Oversight FY14 | 98d | 2013-10-01 A | 2014-02-28 | 25512010a FS-100d | 23% | 75d |  |  | 89d | 22d | 8/5 M-F w/JLAB Holidays ReBaseline | MECH ENG [7.93 h] | 592.13 | 138.97 | 76.53061224 | 23.46938775 | 100 | 100 |  | 40.67954397 | CHUDAKOV | 1 | 1 |  | D |  | E | EUGENE C |  |  |  | 11-006 | 11-026 | 12-034 |  |  |  |  |  |  |  | 12-021 |  |  |  | 12-054 |  |  |  | 25512010a | 13-007 | EJ | 13-015 |  | PR | 98.2940946 |  |  | 14-001 |  |
| 25512065 |  | Manufacturing Drawings for microscope cooling FY13 | 20d | 2013-10-01 A | 2014-02-06 | 9-130M FS+228d | 20% | 59d | 2013-11-01 | 2013-12-02 | 69d | 0d | 8/5 M-F w/JLAB Holidays ReBaseline | MECH ENG [15.01 h]; MECH DES [17.74 h] | 2,030.87 | 569.64 |  |  |  |  |  | 393.597689 | CHUDAKOV | 1 | 1 |  | D |  | S | EUGENE C |  |  |  |  |  |  |  |  |  |  |  |  |  |  |  |  |  |  | ST |  |  | 25512065 | 13-007 | PE | 13-015 |  | PR |  |  |  |  |  |
| 25512065a |  | Manufacturing Drawings for microscope cooling FY14 | 82d | 2013-10-01 A | 2014-02-06 | 25512065 FS-70d | 20% | 59d | 2013-12-03 | 2014-04-08 | 69d | 0d | 8/5 M-F w/JLAB Holidays ReBaseline | MECH ENG [61.55 h]; MECH DES [72.74 h] | 8,327.49 | 2,335.76 |  |  |  |  |  | 1665.498151 | CHUDAKOV | 1 | 1 |  | D |  | S | EUGENE C |  |  |  |  |  |  |  |  |  |  |  |  |  |  |  |  |  |  | ST |  |  | 25512065 | 13-007 | PE | 13-015 |  | PR |  |  |  | 14-001 |  |
| 25512060 |  | Fab Hodoscope mag shields | 37d | 2013-12-03 | 2014-02-04 | 25512056 |  |  |  |  | 107d | 40d | 8/5 M-F w/JLAB Holidays ReBaseline | PROCUREMENT<$50K 60 | 8,255.2 |  |  |  |  |  |  | 0 | CHUDAKOV | 1 | 1 |  | D |  | D | EUGENE C |  |  |  |  |  |  |  | 8255.2 | 0 | 0 | 100 |  |  |  |  |  |  |  |  |  |  | 25512060 | 13-007 |  | 13-015 |  | PR |  | PE |  | 14-001 |  |
| 25512070 |  | Fab microscope cooling | 23d | 2014-02-26 | 2014-03-28 | 25512065 FS+13d, 25512065a FS+13d |  |  |  |  | 69d | 2d | 8/5 M-F w/JLAB Holidays ReBaseline | PROCUREMENT<$50K 60; SUPPLIES & MATERIALS | 7,326.49 |  |  |  |  |  |  | 0 | CHUDAKOV | 1 | 1 |  | D |  | D | EUGENE C |  |  |  |  |  |  |  | 6088.21 | 0 | 0 | 100 |  |  |  |  |  |  |  |  |  |  | 25512070 | 13-007 |  | 13-015 |  | PR |  | EJ |  | 14-001 | EJ |

Notes:
- 15512005: Steps: Finalize microscope requirements (done); Finalize fixed array requirements (done); 3D model fixed (done); 3D model micro (done); Make Drawings - microscope support (done); Make Drawings - fixed array support (done); Structural analysis (done); Check Drawings micro (done); Check Drawings fixed (done); Release drawing package (done); Issue procurment (done)
- 25512005: Steps: Make Drawings - microscope support; Check Drawings micro; Release drawing package micro
- 25512005b: Steps: Make Drawings - microscope support; Check Drawings micro; Release drawing package micro
- 25512056: Steps: Check Drawings (done); Release drawing package (done); Issue procurment
- 25512065: Steps: 3D model (done); Pressure system analysis; Make Drawings; Check Drawings; Release drawing package; Issue procurment
- 25512065a: Steps: 3D model (done); Pressure system analysis; Make Drawings; Check Drawings; Release drawing package; Issue procurment

| ID | WBS | Activity | Duration | Start | Finish | Predecessors | Complete | Remaining | Planned start | Planned finish | Total float | Free float | Calendar | Resources | Cost | Actual cost | Calculated Remaining Total Cost | MONTHLY EV COST | RESP - Responsibility | STRT%COMP for CM EVM | FNSH%COMP for CM EVM | 12 GeV 2nd level Critical Path | HALL D Related Milestones | CR 07-024 | EVMS Reporting Codes | CAM RESPONSIBLE | CR 09-014 | CR 09-027 | CR 09-027 Repair | CR 11-006 | CR 11-026 | CR 12-021 | CR 12-054 | MARCH!!! | Activities with Steps | CR 10-042 | Remaining Material Cost Based on % Compl | Claimed Material Cost Based on % Complet | Initial Claimed Material Calc | Claimed Material Divider | LOE % Pre Calc | LOE % | LOE Divider | LOE Multiplier | CR 12-001 | CR 12-053 | Specification | CR 08-016 | ReBaseline Actuals Adjustment | Original Activity ID Rebaseline | PRIOR MONTH EV COST | CR 13-007 | BOE Labor | CR 13-015 | Previously In Progress | Post Rebaseline | CR 14-001 | BOE Procurement | BOE Expenses | Obligated Prior to Rebaseline |
| --- | --- | --- | --- | --- | --- | --- | --- | --- | --- | --- | --- | --- | --- | --- | --- | --- | --- | --- | --- | --- | --- | --- | --- | --- | --- | --- | --- | --- | --- | --- | --- | --- | --- | --- | --- | --- | --- | --- | --- | --- | --- | --- | --- | --- | --- | --- | --- | --- | --- | --- | --- | --- | --- | --- | --- | --- | --- | --- | --- | --- |
|  | 2 | **1.5.5.2 TARGET** |  | 2011-04-01 | 2014-09-03 |  |  |  |  |  |  |  |  |  |  |  |  |  |  |  |  |  |  |  |  |  |  |  |  |  |  |  |  |  |  |  |  |  |  |  |  |  |  |  |  |  |  |  |  |  |  |  |  |  |  |  |  |  |  |  |
| 1552001 |  | Prepare Procurements/Fabrication Packages 2012 (TARGET) | 454d | 2011-04-01 A | 2013-08-23 A | 9-110M FS+120d | 100% |  | 2011-04-01 | 2013-01-30 |  |  |  | MECH DES [160 h]; MECH ENG [160 h] | 18,866.54 | 19,026.59 | 9170.4 | 18340.8 | CHUDAKOV | 1 | 1 | 2 | D | 07-024 | H | EUGENE C | 09-014 | 09-027 | 09-027 | 11-006 | 11-026 | 12-021F | 12-054F | XX |  |  |  |  |  |  |  |  |  |  |  |  |  |  |  |  |  |  |  |  |  |  |  |  |  |  |
| 1552004 |  | Develop gas handling system | 407d | 2011-05-01 A | 2013-02-11 A | 9-110M FS+120d | 100% |  | 2011-05-02 | 2012-12-14 |  |  |  | MECH DES [240 h]; MECH ENG [320 h]; MECH TECH [240 h] | 44,487.65 | 44,611.34 | 0 | 43284 | CHUDAKOV | 1 | 1 |  | D | 07-024 | S | EUGENE C |  | 09-027 | 09-027 | 11-006 | 11-026 | 12-021F | 12-054F | XX | ST |  |  |  |  |  |  |  |  |  |  |  |  |  |  |  |  |  |  |  |  |  |  |  |  |  |
| 1552032 |  | Develop cryo system design | 397.57d | 2011-05-13 A | 2013-08-30 A | 9-110M FS+162d | 100% |  | 2011-05-13 | 2012-12-14 |  |  |  | MECH DES [240 h]; MECH ENG [320 h]; MECH TECH [240 h] | 44,516.18 | 44,997.79 | 8656.8 | 43284 | CHUDAKOV | 1 | 1 |  | D | 07-024 | S | EUGENE C |  | 09-027 | 09-027 | 11-006 | 11-026 | 12-021F | 12-054F | XX | ST | 10-042 |  |  |  |  |  |  |  |  |  |  |  |  |  |  |  |  |  |  |  |  |  |  |  |  |
| 1552030 |  | Proc Liquid Helium refrigerator (TARGET) | 87d | 2011-10-03 A | 2012-02-13 A | 1552002a FS-300d, 1552003 FS-300d, 9-120M, 1552002 FS-300d | 100% |  |  |  |  |  |  | PROCUREMENT>$50K 69; PROCUREMENT<$50K 60 | 56,754.5 |  | 0 | 56754.5 | CHUDAKOV | 1 | 1 |  | D | 07-024 | D | EUGENE C |  | 09-027 | 09-027 | 11-006 | 11-026 | 12-021F | 12-054F |  |  | 10-042 | 0 | 56754.5 | 5675450 | 100 |  |  |  |  |  |  |  |  |  |  |  |  |  |  |  |  |  |  |  |  |
| 1552003 |  | FY12 Engineering Support for Assembly (TARGET) | 132d | 2012-01-03 A | 2012-07-10 A | 9-120M FS+60d | 100% |  |  |  |  |  |  | MECH ENG [240 h]; MECH DES [480 h] | 39,950.4 | 39,950.4 | 0 | 39950.4 | CHUDAKOV | 1 | 1 | 2 | D | 07-024 | E | EUGENE C | 09-014 | 09-027 | 09-027 | 11-006 | 11-026 | 12-021F | 12-054F |  |  |  |  |  |  |  | 5.38461538 | 94.61538461 | 100 | 100 |  |  |  |  |  |  |  |  |  |  |  |  |  |  |  |  |
| 1552002 |  | Evaluate Procuements 2012 (TARGET) FY11 | 52.5d | 2012-02-01 A | 2012-04-16 A | 1552001 FS-300d | 100% |  |  |  |  |  |  | MECH DES [16.16 h]; MECH ENG [32.32 h] | 3,044.71 | 3,044.71 | 0 | 2950.4928 | CHUDAKOV | 1 | 1 | 2 | D | 07-024 | H | EUGENE C | 09-014 | 09-027 | 09-027 | 11-006 | 11-026 | 12-021F | 12-054F |  |  |  |  |  |  |  |  |  |  |  | 12-001 |  |  |  |  |  |  |  |  |  |  |  |  |  |  |  |
| 1552002a |  | Evaluate Procuements 2012 (TARGET) FY12 | 254.5d | 2012-04-17 A | 2013-02-11 A | 1552002 FS-50d | 100% |  | 2012-04-17 | 2013-04-25 |  |  |  | MECH DES [23.84 h]; MECH ENG [47.68 h] | 4,569.79 | 4,553 | 0 | 4491.6944 | CHUDAKOV | 1 | 1 | 2 | D | 07-024 | H | EUGENE C | 09-014 | 09-027 | 09-027 | 11-006 | 11-026 | 12-021F | 12-054F |  |  |  |  |  |  |  |  |  |  |  | 12-001 |  |  |  |  |  |  |  |  |  |  |  |  |  |  |  |
| 1552023 |  | Fab Target Cells (TARGET) Labor Original | 39d | 2012-09-03 A | 2012-10-28 A | 9-120M FS+184d | 100% |  | 2012-09-04 | 2012-10-26 |  |  |  | MECH TECH [33.23 h] | 1,500.94 | 1,500.94 | 0 | 1476.7412 | CHUDAKOV | 1 | 1 |  | D | 07-024 | H | EUGENE C |  | 09-027 | 09-027 | 11-006 | 11-026 | 12-021 | 12-054F |  |  |  |  |  |  |  |  |  |  |  |  |  |  |  |  |  |  |  |  |  |  |  |  |  |  |  |
| 1552023a |  | Fab Target Cells (TARGET) Labor Revised 2012 ETC FY12 | 166d | 2012-09-03 A | 2013-08-30 A | 1552023 FS-20d | 100% |  | 2012-09-04 | 2013-05-07 |  |  |  | MECH TECH [178.64 h] | 8,163.4 | 8,172.92 | 3969.3808 | 7938.7616 | CHUDAKOV | 1 | 1 |  | D | 07-024 | H | EUGENE C |  | 09-027 | 09-027 | 11-006 | 11-026 | 12-021 | 12-054F |  |  |  |  |  |  |  |  |  |  |  |  | 12-053 |  |  |  |  |  |  |  |  |  |  |  |  |  |  |
| 1552023aa |  | Fab Target Cells (TARGET) Labor Revised 2012 ETC FY13 | 166d | 2012-09-03 A | 2013-08-30 A | 1552023a FS-150d | 100% |  | 2012-09-04 | 2013-05-07 |  |  |  | MECH TECH [28.13 h] | 1,285.47 | 1,286.97 | 645.0209 | 1290.0418 | CHUDAKOV | 1 | 1 |  | D | 07-024 | H | EUGENE C |  | 09-027 | 09-027 | 11-006 | 11-026 | 12-021 | 12-054F |  |  |  |  |  |  |  |  |  |  |  |  | 12-053 |  |  |  |  |  |  |  |  |  |  |  |  |  |  |
| 1552025 |  | Fab Target Cells (TARGET) | 166d | 2012-09-03 A | 2013-08-30 A | 9-130M, 1552023 FS-130d, 1552023aa FS-147d, 1552003 FS-130d | 100% |  | 2012-09-04 | 2013-05-07 |  |  |  | PROCUREMENT<$50K 60 | 12,073.29 |  | 3621.987 | 12073.29 | CHUDAKOV | 1 | 1 |  | D | 07-024 | D | EUGENE C |  | 09-027 | 09-027 | 11-006 | 11-026 | 12-021 | 12-054 |  |  |  | 0 | 12073.29 | 1207329 | 100 |  |  |  |  |  |  |  |  |  |  |  |  |  |  |  |  |  |  |  |  |
| 1552027 |  | Burst test target cell | 11d | 2012-10-08 A | 2012-10-22 A | 1552025 FS-102d | 100% |  |  |  |  |  |  | MECH TECH [160 h]; MECH ENG [80 h] | 13,126.4 | 13,126.4 | 0 | 12720 | CHUDAKOV | 1 | 1 |  | D | 07-024 | H | EUGENE C |  | 09-027 | 09-027 | 11-006 | 11-026 | 12-021 | 12-054F |  |  |  |  |  |  |  |  |  |  |  |  |  |  |  |  |  |  |  |  |  |  |  |  |  |  |  |
| 1552033 |  | Procure heat xchngr and cryo hardware | 147d | 2012-12-03 A | 2013-08-30 A | 1552032 FS-55d, 9-130M | 100% |  | 2013-01-31 | 2013-08-28 |  |  |  | PROCUREMENT<$50K 60 | 15,972.26 |  | 11979.195 | 15972.26 | CHUDAKOV | 1 | 1 |  | D | 07-024 | D | EUGENE C |  | 09-027 | 09-027 | 11-006 | 11-026 | 12-021 | 12-054 |  |  | 10-042 | 0 | 15972.26 | 1597226 | 100 |  |  |  |  |  |  |  |  |  |  |  |  |  |  |  |  |  |  |  |  |
| 1552005 |  | Proc Gas Handling Sys (TARGET) | 120d | 2013-02-11 A | 2013-08-30 A | 9-130M FS+90d, 1552004, 1552002a FS-60d | 100% |  | 2013-03-01 | 2013-08-19 |  |  |  | PROCUREMENT>$50K 69 | 28,975.9 |  | 11590.36 | 28975.9 | CHUDAKOV | 1 | 1 |  | D | 07-024 | D | EUGENE C |  | 09-027 | 09-027 | 11-006 | 11-026 | 12-021 | 12-054 |  |  |  | 0 | 28975.9 | 2897590 | 100 |  |  |  |  |  |  |  |  |  |  |  |  |  |  |  |  |  |  |  |  |
| 1552010 |  | Proc Controls (TARGET) | 120d | 2013-02-11 A | 2013-08-30 A | 9-130M | 100% |  | 2013-03-18 | 2013-09-04 |  |  |  | PROCUREMENT>$50K 69 | 41,854.09 |  | 31390.565 | 41854.09 | CHUDAKOV | 1 | 1 |  | D | 07-024 | D | EUGENE C |  |  |  | 11-006 | 11-026 | 12-021 | 12-054 |  |  | 10-042 | 0 | 41854.09 | 4185409 | 100 |  |  |  |  |  |  |  |  |  |  |  |  |  |  |  |  |  |  |  |  |
| 1552015 |  | Fab Isolation Vac Pumping Sys (TARGET) | 83d | 2013-03-04 A | 2013-08-30 A | 1552003 FS-130d, 9-130M | 100% |  | 2013-04-01 | 2013-07-26 |  |  |  | PROCUREMENT<$50K 60 | 27,768.58 |  | 27768.58 | 27768.58 | CHUDAKOV | 1 | 1 |  | D | 07-024 | D | EUGENE C |  | 09-027 | 09-027 | 11-006 | 11-026 | 12-021F | 12-054 |  |  |  | 0 | 27768.58 | 2776858 | 100 |  |  |  |  |  |  |  |  |  |  |  |  |  |  |  |  |  |  |  |  |
| 1552006 |  | Install Gas Handling Sys (TARGET) | 109d | 2013-08-30 A | 2013-08-30 A | 1552005 FS-51d | 100% |  | 2013-09-03 | 2014-02-13 |  |  |  | MECH TECH [208.9 h]; PROCUREMENT>$50K 69 NO ESCALATION FY14 | 9,829.19 | 9,580.15 | 18745.45 | 9580.154 | CHUDAKOV | 1 | 1 |  | D | 07-024 | H | EUGENE C |  | 09-027 | 09-027 | 11-006 | 11-026 | 12-021 | 12-054 |  |  |  |  |  |  |  |  |  |  |  |  |  | 1552006 |  |  |  |  |  |  |  |  |  |  |  |  |  |
| 1552018 |  | Fab Outer Vac/Scattering Chamb (TARGET) Labor Original | 18d | 2013-08-30 A | 2013-08-30 A | 9-130M FS+150d, 9-120M FS+184d | 100% |  | 2013-09-03 | 2013-09-26 |  |  |  | MECH ENG [5.54 h]; MECH TECH [33.23 h] | 1,924.8 | 1,924.8 | 1865.206 | 1865.206 | CHUDAKOV | 1 | 1 |  | D | 07-024 | H | EUGENE C |  | 09-027 | 09-027 | 11-006 | 11-026 | 12-021 | 12-054F | XX |  |  |  |  |  |  |  |  |  |  |  |  |  |  |  |  |  |  |  |  |  |  |  |  |  |  |
| 1552018a |  | Fab Outer Vac/Scattering Chamb (TARGET) Labor Revised 2012 ETC | 102d | 2013-08-30 A | 2013-08-30 A | 1552018 | 100% |  | 2013-09-27 | 2014-03-03 |  |  |  | MECH ENG [34.46 h]; MECH TECH [206.77 h] | 12,350.01 | 11,976 | 11605.194 | 11605.194 | CHUDAKOV | 1 | 1 |  | D | 07-024 | H | EUGENE C |  | 09-027 | 09-027 | 11-006 | 11-026 | 12-021 | 12-054F |  |  |  |  |  |  |  |  |  |  |  |  |  |  |  |  |  |  |  |  |  |  |  |  |  |  |  |
| 1552020 |  | Fab Outer Vac/Scattering Chamb (TARGET) | 90d | 2013-08-30 A | 2013-08-30 A | 9-130M FS+100d, 1552018 FS-130d, 1552018a FS-127d, 1552003 FS-130d | 100% |  | 2013-09-03 | 2014-01-16 |  |  |  | PROCUREMENT<$50K 60 | 10,865.96 |  | 10865.96 | 10865.96 | CHUDAKOV | 1 | 1 |  | D | 07-024 | D | EUGENE C |  | 09-027 | 09-027 | 11-006 | 11-026 | 12-021 | 12-054 |  |  |  | 0 | 10865.96 | 1086596 | 100 |  |  |  |  |  |  |  |  |  |  |  |  |  |  |  |  |  |  |  |  |
| 1552028 |  | Prepare Procurements/Fabrication Packages solid target (TARGET) | 63d | 2013-08-30 A | 2013-08-30 A | 9-130M FS+163d | 100% |  | 2013-09-03 | 2013-12-02 |  |  |  | MECH TECH [240 h] | 11,245.56 | 11,006.4 | 11006.4 | 11006.4 | CHUDAKOV | 1 | 1 |  | D | 07-024 | H | EUGENE C |  | 09-027 | 09-027 | 11-006 | 11-026 | 12-021F | 12-054 |  |  |  |  |  |  |  |  |  |  |  |  |  |  |  |  |  |  |  |  |  |  |  |  |  |  |  |
| 1552028b |  | Fabricate solid target (labor) | 63d | 2013-08-30 A | 2013-08-30 A | 1552028 | 100% |  | 2013-12-03 | 2014-03-11 |  |  |  | MECH TECH [10.16 h]; MECH DES [1.27 h]; MECH ENG [1.27 h] | 640.75 | 620.97 | 19558 | 620.9665 | CHUDAKOV | 1 | 1 |  | D | 07-024 | S | EUGENE C |  | 09-027 | 09-027 | 11-006 | 11-026 | 12-021F | 12-054 |  | ST |  |  |  |  |  |  |  |  |  |  |  |  |  |  |  |  |  |  |  |  |  |  |  |  |  |
| 1552035 |  | Fab Positioning/Mounting Sys (TARGET) | 49d | 2013-08-30 A | 2013-08-30 A | 9-130M FS+145d | 100% |  | 2013-09-03 | 2013-11-08 |  |  |  | PROCUREMENT<$50K 60 | 59,159.13 |  | 59159.13 | 59159.13 | CHUDAKOV | 1 | 1 |  | D | 07-024 | D | EUGENE C |  | 09-027 | 09-027 | 11-006 | 11-026 | 12-021 | 12-054 |  |  |  | 0 | 59159.13 | 5915913 | 100 |  |  |  |  |  |  |  |  |  |  |  |  |  |  |  |  |  |  |  |  |
| 1552040 |  | Assemble Target (TARGET) | 128d | 2013-08-30 A | 2013-08-30 A | 1552030, 1552010 FS-112d, 1552033, 9-130M FS+6d, 1552035, 1552005 FS-112d, 1552006 FS-170d, 1552028b FS-190d, 1552020, 1552045 FS-150d, 1552015 FS-60d, 1552025, 1552027 | 100% |  | 2014-01-17 | 2014-07-21 |  |  |  | MECH TECH [59.06 h]; MECH ENG [13.13 h] | 3,775.01 | 3,658.46 | 22298.4 | 3658.457958 | CHUDAKOV | 1 | 1 |  | D | 07-024 | H | EUGENE C |  |  |  | 11-006 | 11-026 | 12-021 | 12-054 |  |  |  |  |  |  |  |  |  |  |  |  |  |  | 08-016 |  |  |  |  |  |  |  |  |  |  |  |  |
| 1552045 |  | Program controls | 54d | 2013-08-30 A | 2013-08-30 A | 9-130M FS+150d | 100% |  | 2013-09-03 | 2013-11-15 |  |  |  |  |  |  |  | 0 | CHUDAKOV | 1 | 1 |  | D | 07-024 | Z | EUGENE C |  |  |  | 11-006 | 11-026 | 12-021 | 12-054F |  |  |  |  |  |  |  |  |  |  |  |  |  |  | 08-016 |  |  |  |  |  |  |  |  |  |  |  |  |
| 1552050 |  | Re-Baseline Actuals Adjustment | 1d | 2013-08-30 A | 2013-08-30 A |  | 100% |  | 2013-09-03 | 2013-09-03 |  |  |  | PROCUREMENT>$50K 69 NO ESCALATION | 45,207.1 |  |  | 45207.1 |  |  |  |  |  |  |  |  |  |  |  |  |  |  |  |  |  |  | 0 | 45207.1 | 4520710 | 100 |  |  |  |  |  |  |  |  | ADJ |  |  |  |  |  |  |  |  |  |  |  |
| 2552001 |  | Prepare Procurements/Fabrication Packages FY13 (TARGET) | 20d | 2013-09-03 A | 2013-11-15 | 9-130M FS+228d | 60% | 11d | 2013-10-01 | 2013-10-28 | 13d | 0d | 8/5 M-F w/JLAB Holidays ReBaseline | MECH DES [8 h]; MECH ENG [8 h] | 1,007.76 | 790.92 |  | 0 | CHUDAKOV | 1 | 1 | 2 | D | 07-024 | S | EUGENE C | 09-014 | 09-027 | 09-027 | 11-006 | 11-026 | 12-021F | 12-054F |  | ST |  |  |  |  |  |  |  |  |  |  |  |  |  |  | 2552001 | 585.936 | 13-007F | PE | 13-015 | Review | PR |  |  |  |  |
| 2552001a |  | Prepare Procurements/Fabrication Packages FY14 (TARGET) | 10d | 2013-09-03 A | 2013-11-15 | 2552001 FS-40d | 60% | 11d | 2013-10-01 | 2013-10-14 | 13d | 0d | 8/5 M-F w/JLAB Holidays ReBaseline | MECH DES [4 h]; MECH ENG [4 h] | 503.88 | 395.46 |  | 0 | CHUDAKOV | 1 | 1 | 2 | D | 07-024 | S | EUGENE C | 09-014 | 09-027 | 09-027 | 11-006 | 11-026 | 12-021F | 12-054F |  | ST |  |  |  |  |  |  |  |  |  |  |  |  |  |  | 2552001 | 302.328 | 13-007F | PE | 13-015 | Review | PR | 14-001 |  |  |  |
| 2552005 |  | Proc Gas Handling Sys (TARGET) - Procurement | 50d | 2013-09-03 A | 2013-11-15 | 9-130M FS+228d | 75% | 11d | 2013-10-01 | 2013-12-11 | 64d | 0d | 8/5 M-F w/JLAB Holidays ReBaseline | SUPPLIES & MATERIALS; PROCUREMENT>$50K 69 NO ESCALATION FY14 | 7,800 |  |  | 5460 | CHUDAKOV | 1 | 1 |  | D | 07-024 | D | EUGENE C |  | 09-027 | 09-027 | 11-006 | 11-026 | 12-021 | 12-054 |  |  |  | 1950 | 5850 | 585000 | 100 |  |  |  |  |  |  |  |  |  | 2552005 | 390 | 13-007F |  | 13-015 |  | PR |  | PE | EJ | OB-2 |
| 2552005a |  | Proc Gas Handling Sys (TARGET) - Expenses FY13 | 20d | 2013-09-03 A | 2013-11-15 | 9-130M FS+228d | 75% | 11d | 2013-09-03 | 2013-09-30 | 113d | 49d | 8/5 M-F w/JLAB Holidays ReBaseline | SUPPLIES & MATERIALS | 3,632 |  |  | 2542.4 | CHUDAKOV | 1 | 1 |  | D | 07-024 | D | EUGENE C |  | 09-027 | 09-027 | 11-006 | 11-026 | 12-021 | 12-054 |  |  |  |  |  |  |  |  |  |  |  |  |  |  |  |  | 2552005 | 181.6 | 13-007F |  | 13-015 |  | PR |  | PE | EJ |  |
| 2552005b |  | Proc Gas Handling Sys (TARGET) - Expenses FY14 | 30d | 2013-09-03 A | 2013-11-15 | 2552005a FS-60d | 75% | 11d | 2013-10-01 | 2013-11-11 | 64d | 0d | 8/5 M-F w/JLAB Holidays ReBaseline | SUPPLIES & MATERIALS | 5,621.79 |  |  | 3935.253 | CHUDAKOV | 1 | 1 |  | D | 07-024 | D | EUGENE C |  | 09-027 | 09-027 | 11-006 | 11-026 | 12-021 | 12-054 |  |  |  |  |  |  |  |  |  |  |  |  |  |  |  |  | 2552005 | 281.0895 | 13-007F |  | 13-015 |  | PR | 14-001 | PE | EJ |  |
| 2552010 |  | Proc Controls (TARGET) - Procurement | 65d | 2013-09-03 A | 2013-12-04 | 9-130M FS+228d | 70% | 22d | 2013-10-01 | 2014-01-13 | 167d | 48d | 8/5 M-F w/JLAB Holidays ReBaseline | SUPPLIES & MATERIALS; PROCUREMENT>$50K 69 NO ESCALATION FY14 | 7,000 |  |  | 3500 | CHUDAKOV | 1 | 1 |  | D | 07-024 | D | EUGENE C |  |  |  | 11-006 | 11-026 | 12-021 | 12-054 |  |  | 10-042 | 2100 | 4900 | 490000 | 100 |  |  |  |  |  |  |  |  |  | 2552010 | 1400 | 13-007F |  | 13-015 |  | PR |  | PE | PE | OB-2 |
| 2552010a |  | Proc Controls (TARGET) - Expenses FY13 | 20d | 2013-09-03 A | 2013-12-04 | 9-130M FS+228d | 70% | 22d | 2013-09-03 | 2013-09-30 | 220d | 53d | 8/5 M-F w/JLAB Holidays ReBaseline | SUPPLIES & MATERIALS | 230.77 |  |  | 115.385 | CHUDAKOV | 1 | 1 |  | D | 07-024 | D | EUGENE C |  |  |  | 11-006 | 11-026 | 12-021 | 12-054 |  |  | 10-042 |  |  |  |  |  |  |  |  |  |  |  |  |  | 2552010 | 46.154 | 13-007F |  | 13-015 |  | PR |  | PE | PE |  |
| 2552010b |  | Proc Controls (TARGET) - Expenses FY14 | 45d | 2013-09-03 A | 2013-12-04 | 2552010a FS-75d | 70% | 22d | 2013-10-01 | 2013-12-04 | 167d | 48d | 8/5 M-F w/JLAB Holidays ReBaseline | SUPPLIES & MATERIALS | 535.79 |  |  | 267.895 | CHUDAKOV | 1 | 1 |  | D | 07-024 | D | EUGENE C |  |  |  | 11-006 | 11-026 | 12-021 | 12-054 |  |  | 10-042 |  |  |  |  |  |  |  |  |  |  |  |  |  | 2552010 | 107.158 | 13-007F |  | 13-015 |  | PR | 14-001 | PE | PE |  |
| 2552012 |  | Program Target Controls | 52d | 2013-09-03 A | 2013-12-19 | 2552010b FS-70d, 2552010 FS-70d | 25% | 33d | 2013-11-04 | 2014-01-29 | 214d |  | 8/5 M-F w/JLAB Holidays ReBaseline | COMP SCIENT [160 h] | 11,179.2 | 6,234.13 |  | 0 | CHUDAKOV | 1 | 1 |  | D | 07-024 | S | EUGENE C |  |  |  | 11-006 | 11-026 | 12-021 | 12-054F |  | ST |  |  |  |  |  |  |  |  |  |  |  |  | 08-016 |  | 2552012 | 2794.8 | 13-007 | EJ | 13-015 |  | PR | 14-001 |  |  |  |
| 2552015 |  | Fab Isolation Vac Pumping Sys (TARGET) (Previously Obligated) | 51d | 2013-09-03 A | 2013-09-23 A | 2552001a FS-30d, 2552001 FS-30d | 100% |  | 2013-10-01 | 2013-12-12 |  |  | 8/5 M-F w/JLAB Holidays ReBaseline | PROCUREMENT<$50K 60 NO ESCALATION FY14 | 11,509 |  |  | 0 | CHUDAKOV | 1 | 1 |  | D | 07-024 | D | EUGENE C |  | 09-027 | 09-027 | 11-006 | 11-026 | 12-021F | 12-054 |  |  |  | 0 | 11509 | 1150900 | 100 |  |  |  |  |  |  |  |  |  | 2552015 | 11509 | 13-007F |  | 13-015 |  | PR |  | PE | EJ | OB |
| 2552015a |  | Fab Isolation Vac Pumping Sys (TARGET) | 51d | 2013-09-03 A | 2013-11-12 | 2552001 FS-30d, 2552001a FS-30d | 10% | 8d | 2013-10-01 | 2013-12-12 | 129d |  | 8/5 M-F w/JLAB Holidays ReBaseline | PROCUREMENT<$50K 60 NO ESCALATION FY14 | 14,887.99 |  |  | 0 | CHUDAKOV | 1 | 1 |  | D | 07-024 | D | EUGENE C |  | 09-027 | 09-027 | 11-006 | 11-026 | 12-021F | 12-054 |  |  |  | 13399.191 | 1488.799 | 148879.9 | 100 |  |  |  |  |  |  |  |  |  | 2552015 | 1488.799 | 13-007F |  | 13-015 |  | PR |  | PE | EJ | OB-2 |
| 2552023aa |  | Fab Target Cells (TARGET) FY13 | 109d | 2013-09-03 A | 2014-02-17 | 9-130M FS+228d | 50% | 66d | 2013-10-01 | 2014-03-17 | 11d |  | 8/5 M-F w/JLAB Holidays ReBaseline | SUPPLIES & MATERIALS; MECH TECH [14.49 h] | 916.86 | 266.61 |  | 0 | CHUDAKOV | 1 | 1 |  | D | 07-024 | S | EUGENE C |  | 09-027 | 09-027 | 11-006 | 11-026 | 12-021 | 12-054F |  | ST |  |  |  |  |  |  |  |  |  |  | 12-053 |  |  |  | 2552023aa | 447.8507 | 13-007F | PE | 13-015 |  | PR |  |  | PE |  |
| 2552023aaa |  | Fab Target Cells (TARGET) FY14 | 89d | 2013-09-03 A | 2014-02-17 | 2552023aa FS-100d | 50% | 66d | 2013-10-01 | 2014-02-17 | 11d |  | 8/5 M-F w/JLAB Holidays ReBaseline | SUPPLIES & MATERIALS; MECH TECH [64.46 h] | 4,111.87 | 1,186.04 |  | 0 | CHUDAKOV | 1 | 1 |  | D | 07-024 | S | EUGENE C |  | 09-027 | 09-027 | 11-006 | 11-026 | 12-021 | 12-054F |  | ST |  |  |  |  |  |  |  |  |  |  | 12-053 |  |  |  | 2552023aa | 2055.9336 | 13-007F | PE | 13-015 |  | PR | 14-001 |  | PE |  |
| 2552032 |  | Manufacturing Drawings for cryo system (Target) FY13 | 30d | 2013-09-03 A | 2013-11-14 | 9-130M FS+228d | 45% | 10d | 2013-10-01 | 2013-11-11 | 97d | 5d | 8/5 M-F w/JLAB Holidays ReBaseline | MECH DES [28.8 h]; MECH ENG [32.4 h] | 3,896.75 | 2,517.41 |  | 377.6112 | CHUDAKOV | 1 | 1 |  | D | 07-024 | S | EUGENE C |  | 09-027 | 09-027 | 11-006 | 11-026 | 12-021F | 12-054F |  | ST | 10-042 |  |  |  |  |  |  |  |  |  |  |  |  |  | 2552032 | 1321.6392 | 13-007F | PE | 13-015 | Review | PR |  |  |  |  |
| 2552032a |  | Manufacturing Drawings for cryo system (Target) FY14 | 10d | 2013-09-03 A | 2013-11-14 | 2552032 FS-15d | 45% | 10d | 2013-10-01 | 2013-10-14 | 97d | 20d | 8/5 M-F w/JLAB Holidays ReBaseline | MECH DES [14.4 h]; MECH ENG [16.2 h] | 1,948.37 | 1,258.71 |  | 194.8374 | CHUDAKOV | 1 | 1 |  | D | 07-024 | S | EUGENE C |  | 09-027 | 09-027 | 11-006 | 11-026 | 12-021F | 12-054F |  | ST | 10-042 |  |  |  |  |  |  |  |  |  |  |  |  |  | 2552032 | 681.9309 | 13-007F | PE | 13-015 | Review | PR | 14-001 |  |  |  |
| 2552033 |  | Procure heat xchngr and cryo hardware | 20d | 2013-09-03 A | 2013-10-21 A | 2552032a FS-30d, 2552032 FS-30d | 100% |  | 2013-10-01 | 2013-10-28 |  |  | 8/5 M-F w/JLAB Holidays ReBaseline | PROCUREMENT<$50K 60 | 1,650 |  |  | 330 | CHUDAKOV | 1 | 1 |  | D | 07-024 | D | EUGENE C |  | 09-027 | 09-027 | 11-006 | 11-026 | 12-021 | 12-054 |  |  | 10-042 | 0 | 1650 | 165000 | 100 |  |  |  |  |  |  |  |  |  | 2552033 | 1320 | 13-007F |  | 13-015 |  | PR |  | OB |  | OB-2 |
| 2552008 |  | Manufacturing Drawings for gas System (Target) FY13 | 20d | 2013-10-01 A | 2013-12-05 | 9-130M FS+228d, 9-140M FS+23d | 40% | 23d | 2013-11-01 | 2013-12-02 | 96d | 7d | 8/5 M-F w/JLAB Holidays ReBaseline | MECH ENG [17.39 h]; MECH DES [19.88 h] | 2,318.42 | 1,159.21 |  | 898.6542428 | CHUDAKOV | 1 | 1 |  | D |  | S | EUGENE C |  |  |  |  |  |  |  |  | ST |  |  |  |  |  |  |  |  |  |  |  |  |  |  | 2552008 |  | 13-007 | PE | 13-015 |  | PR |  |  |  |  |
| 2552008a |  | Manufacturing Drawings for gas System (Target) FY14 | 46d | 2013-10-01 A | 2013-12-05 | 2552008 FS-30d | 40% | 23d | 2013-12-03 | 2014-02-17 | 96d | 21d | 8/5 M-F w/JLAB Holidays ReBaseline | MECH ENG [40.01 h]; MECH DES [45.72 h] | 5,332.92 | 2,666.46 |  | 2133.1681488 | CHUDAKOV | 1 | 1 |  | D |  | S | EUGENE C |  |  |  |  |  |  |  |  | ST |  |  |  |  |  |  |  |  |  |  |  |  |  |  | 2552008 |  | 13-007 | PE | 13-015 |  | PR | 14-001 |  |  |  |
| 2552018a |  | Fab Outer Vac/Scattering Chamb (TARGET) | 38d | 2013-12-11 | 2014-02-13 | 2552001a FS+15d, 2552001 FS+15d |  |  |  |  | 13d |  | 8/5 M-F w/JLAB Holidays ReBaseline | SUPPLIES & MATERIALS; MECH ENG [40 h]; MECH TECH [240 h] | 25,556.23 |  |  | 0 | CHUDAKOV | 1 | 1 |  | D | 07-024 | S | EUGENE C |  | 09-027 | 09-027 | 11-006 | 11-026 | 12-021 | 12-054F |  | ST |  |  |  |  |  |  |  |  |  |  |  |  |  |  | 2552018a |  | 13-007F | PE | 13-015 | Review | PR | 14-001 |  | EJ |  |
| 2552035 |  | Fab Positioning/Mounting Sys (TARGET) | 42d | 2014-01-03 | 2014-03-04 | 2552001, 2552001a, 9-140M FS+60d |  |  |  |  | 0d |  | 8/5 M-F w/JLAB Holidays ReBaseline | PROCUREMENT<$50K 60; SUPPLIES & MATERIALS | 16,716.78 |  |  | 0 | CHUDAKOV | 1 | 1 |  | D | 07-024 | D | EUGENE C |  | 09-027 | 09-027 | 11-006 | 11-026 | 12-021 | 12-054 |  |  |  | 13001.94 | 0 | 0 | 100 |  |  |  |  |  |  |  |  |  | 2552035 |  | 13-007F |  | 13-015 |  | PR | 14-001 | PE | EJ |  |
| 2552007 |  | Install Gas Tank (TARGET) | 18d | 2014-01-08 | 2014-02-03 | 2552001, 2552005b FS-16d, 9-140M FS+63d, 2552001a, 2552005 FS-16d |  |  |  |  | 21d |  | 8/5 M-F w/JLAB Holidays ReBaseline | PROCUREMENT>$50K 69 | 19,090.15 |  |  | 0 | CHUDAKOV | 1 | 1 |  | D | 07-024 | S | EUGENE C |  | 09-027 | 09-027 | 11-006 | 11-026 | 12-021 | 12-054 |  |  |  | 19090.15 | 0 | 0 | 100 |  |  |  |  |  |  |  |  |  | 2552007 |  | 13-007 |  | 13-015 |  | PR | 14-001 | PE |  |  |
| 2552006 |  | Install Gas Handling Sys (TARGET) | 86d | 2014-01-16 | 2014-05-16 | 2552008, 2552005b FS+33d, 2552005 FS+33d, 2552008a |  |  |  |  | 75d |  | 8/5 M-F w/JLAB Holidays ReBaseline | MECH TECH [329.6 h]; SUPPLIES & MATERIALS; MECH ENG [20 h]; MECH DES [16 h] | 18,426.82 |  |  | 0 | CHUDAKOV | 1 | 1 |  | D | 07-024 | S | EUGENE C |  | 09-027 | 09-027 | 11-006 | 11-026 | 12-021 | 12-054 |  | ST |  |  |  |  |  |  |  |  |  |  |  |  |  |  | 2552006 |  | 13-007 | EJ | 13-015 |  | PR | 14-001 |  | EJ |  |
| 2552028 |  | Prepare Procurements/Fabrication Packages solid target (TARGET) | 42d | 2014-01-30 | 2014-03-28 | 9-140M FS+78d |  |  |  |  | 133d | 0d | 8/5 M-F w/JLAB Holidays ReBaseline | MECH TECH [240 h]; MECH ENG [100 h]; MECH DES [164 h] | 27,237 |  |  | 0 | CHUDAKOV | 1 | 1 |  | D | 07-024 | S | EUGENE C |  | 09-027 | 09-027 | 11-006 | 11-026 | 12-021F | 12-054 |  | ST |  |  |  |  |  |  |  |  |  |  |  |  |  |  | 2552028 |  | 13-007F | PE | 13-015 |  | PR | 14-001 |  |  |  |
| 2552040 |  | Assemble Target (TARGET) | 128d | 2014-03-05 | 2014-09-03 | 2552028a FS-190d, 2552015a FS-60d, 2552018a, 2552015 FS-60d, 2552033, 2552035, 2552028b FS-190d, 2552007, 2552023aaa, 2552006 FS-170d, 2552012 FS-170d, 2552010 FS-112d, 2552023aa, 2552010b FS-112d |  |  |  |  | 0d |  | 8/5 M-F w/JLAB Holidays ReBaseline | MECH ENG [80 h]; MECH TECH [360 h] | 23,008.8 |  |  | 0 | CHUDAKOV | 1 | 1 |  | D | 07-024 | S | EUGENE C |  |  |  | 11-006 | 11-026 | 12-021 | 12-054 |  | ST |  |  |  |  |  |  |  |  |  |  |  |  | 08-016 |  | 2552040 |  | 13-007F | EJ | 13-015 |  | PR | 14-001 |  |  |  |
| 2552028a |  | Fabricate solid target (proc) | 38d | 2014-04-01 | 2014-05-22 | 2552028 FS+1d |  |  |  |  | 133d |  | 8/5 M-F w/JLAB Holidays ReBaseline | SUPPLIES & MATERIALS | 15,272.12 |  |  | 0 | CHUDAKOV | 1 | 1 |  | D | 07-024 | D | EUGENE C |  | 09-027 | 09-027 | 11-006 | 11-026 | 12-021F | 12-054 |  |  |  |  |  |  |  |  |  |  |  |  |  |  |  |  | 2552028a |  | 13-007F |  | 13-015 |  | PR | 14-001 |  | EJ |  |
| 2552028b |  | Fabricate solid target (labor) | 38d | 2014-04-01 | 2014-05-22 | 2552028 FS+1d |  |  |  |  | 133d |  | 8/5 M-F w/JLAB Holidays ReBaseline | MECH TECH [320 h]; MECH DES [40 h]; MECH ENG [40 h] | 20,181.2 |  |  | 0 | CHUDAKOV | 1 | 1 |  | D | 07-024 | S | EUGENE C |  | 09-027 | 09-027 | 11-006 | 11-026 | 12-021F | 12-054 |  | ST |  |  |  |  |  |  |  |  |  |  |  |  |  |  | 2552028b |  | 13-007F | EJ | 13-015 |  | PR | 14-001 |  |  |  |

Notes:
- 1552004: Steps: Develop preliminaty requirements document (done); Develop Final requirements document (done); Preliminary P&I diagram (done); Final P&I Diagram (done); Define hardware (done); Complete analysis documentation (done); Complete procurement/Fab documentation (done)
- 1552032: Steps: Develop preliminaty requirements document (done); Develop Final requirements document (done); Preliminary P&I diagram (done); Final P&I Diagram (done); Define hardware (done); Complete analysis documentation (done); Complete procurement/Fab documentation (done)
- 1552028b: Steps: Fabricate solid target (labor) (done)
- 2552001: Steps: installation cart requirements (done); Make Drawings for installation cart; Release drawing package scattering; Release drawing package insertion
- 2552001a: Steps: installation cart requirements (done); Make Drawings for installation cart; Release drawing package scattering; Release drawing package insertion
- 2552012: Steps: Develop Logic (done); Write initial control program; Document final controls
- 2552023aa: Steps: fab production cells (2) cylinders and windows (done); glue cylinders to base and window
- 2552023aaa: Steps: fab production cells (2) cylinders and windows (done); glue cylinders to base and window
- 2552032: Steps: Pressure system analysis (done); Check Drawings; Release drawing package; Issue procurment (done)
- 2552032a: Steps: Pressure system analysis (done); Check Drawings; Release drawing package; Issue procurment (done)
- 2552008: Steps: ___Make_P&I (done); ___Make_Fab_Drawings_(target_group) (done); ___Make_Final_Drawings; __Check_Drawings; __Release_drawing_package; __Issue_procurment
- 2552008a: Steps: ___Make_P&I (done); ___Make_Fab_Drawings_(target_group) (done); ___Make_Final_Drawings; __Check_Drawings; __Release_drawing_package; __Issue_procurment
- 2552018a: Steps: fab assy mandrel; machine rohacel; fab base; glue rohacel sections; glue rohacel to base
- 2552006: Steps: install supply piping in hall; install return piping in hall; install vent pipe to outside; install piping to tank; install gauging and valves on tank; test and purge system
- 2552028: Steps: Finalize requirements; 3D model; Make Drawings; Check Drawings; Release drawing package; Issue procurment
- 2552040: Steps: Mount vacuum chamber onto insertion cart; install cold head on vacuum chamber; install cryogenic lines and chilled water; mount cell onto support structure; install thermal shielding; leak check cryo circuit; attach cell to cryo lines; fiducialize cell; attach scattering chamber; leak check vacuum space; hook up compressor; install gas panel on installation cart; Test systems
- 2552028b: Steps: mount foil on holder; assemble holder into support; assemble onto insertion cart

| ID | WBS | Activity | Duration | Start | Finish | Predecessors | Complete | Remaining | Planned start | Planned finish | Total float | Free float | Calendar | Resources | Cost | Actual cost | LOE Divider | LOE Multiplier | Calculated Remaining Total Cost | MONTHLY EV COST | RESP - Responsibility | STRT%COMP for CM EVM | FNSH%COMP for CM EVM | HALL D Related Milestones | CR 07-024 | EVMS Reporting Codes | CAM RESPONSIBLE | CR 11-006 | CR 11-026 | 12 GeV 2nd level Critical Path | CR 09-014 | CR 09-027 | CR 09-027 Repair | CR 12-021 | LOE % Pre Calc | LOE % | CR 11-004 | Remaining Material Cost Based on % Compl | Claimed Material Cost Based on % Complet | Initial Claimed Material Calc | Claimed Material Divider | Specification | CR 12-054 | MARCH!!! | CR 08-016 | CR 09-012 | CR 12-055 | CR 12-053 | ReBaseline Actuals Adjustment | Original Activity ID Rebaseline | PRIOR MONTH EV COST | BOE Labor | CR 13-015 | Post Rebaseline | BOE Procurement | Obligated Prior to Rebaseline | CR 13-007 | Activities with Steps | CR 14-001 |
| --- | --- | --- | --- | --- | --- | --- | --- | --- | --- | --- | --- | --- | --- | --- | --- | --- | --- | --- | --- | --- | --- | --- | --- | --- | --- | --- | --- | --- | --- | --- | --- | --- | --- | --- | --- | --- | --- | --- | --- | --- | --- | --- | --- | --- | --- | --- | --- | --- | --- | --- | --- | --- | --- | --- | --- | --- | --- | --- | --- |
|  | 3 | **1.5.5.3 BEAMLINE COMPONENTS** |  | 2009-10-01 | 2015-04-01 |  |  |  |  |  |  |  |  |  |  |  |  |  |  |  |  |  |  |  |  |  |  |  |  |  |  |  |  |  |  |  |  |  |  |  |  |  |  |  |  |  |  |  |  |  |  |  |  |  |  |  |  |  |  |
| 1553010E |  | FY10 Travel (BL Compnts) | 248d | 2009-10-01 A | 2010-09-30 A | 9-100M | 100% |  |  |  |  |  |  | TRAVEL | 879.02 |  | 100 | 100 | 0 | 879.024015 | CHUDAKOV | 1 | 1 | D | 07-024 | E | EUGENE C | 11-006 | 11-026 |  |  |  |  |  |  |  |  |  |  |  |  |  |  |  |  |  |  |  |  |  |  |  |  |  |  |  |  |  |  |
| 1553085 |  | Design Primary Collimator Support (BL Compnts) | 317d | 2010-07-19 A | 2011-10-24 A | 9-100M | 100% |  |  |  |  |  |  | MECH DES [440 h] | 20,466.36 | 20,466.36 |  |  | 0 | 21194.8 | CHUDAKOV | 1 | 1 | D |  | H | EUGENE C |  | 11-026 |  |  |  |  |  |  |  |  |  |  |  |  |  |  |  |  |  |  |  |  |  |  |  |  |  |  |  |  |  |  |
| 1553001 |  | Engineering Support for Obtaining/Tstng Pair Spectrmtr Mag (BL Compnts) | 65d | 2010-10-01 A | 2011-01-11 A | 9-110M | 100% |  |  |  |  |  |  | MECH ENG [80 h]; MECH DES [240 h] | 16,639.2 | 16,639.2 | 100 | 100 | 0 | 16639.2 | CHUDAKOV | 1 | 1 | D | 07-024 | E | EUGENE C |  | 11-026 | 2 | 09-014 | 09-027 | 09-027 | 12-021F |  |  |  |  |  |  |  |  |  |  |  |  |  |  |  |  |  |  |  |  |  |  |  |  |  |
| 1553011E |  | FY11 Travel (BL Compnts) | 248d | 2010-10-01 A | 2011-09-30 A | 1553010E | 100% |  |  |  |  |  |  | TRAVEL | 907.06 |  | 100 | 100 | 0 | 907.06 | CHUDAKOV | 1 | 1 | D | 07-024 | E | EUGENE C | 11-006 | 11-026 |  |  |  |  |  | 8.46774193 | 91.53225806 |  |  |  |  |  |  |  |  |  |  |  |  |  |  |  |  |  |  |  |  |  |  |  |
| 1553030 |  | Obtain Surplus Mag (BL Compnts) | 157d | 2010-10-01 A | 2011-05-23 A | 1553001 FS-65d, 9-110M | 100% |  |  |  |  |  |  | SCIENTIST [160 h] | 10,948.8 | 10,948.8 |  |  | 0 | 10948.8 | CHUDAKOV | 1 | 1 | D |  | H | EUGENE C |  | 11-026 |  | 09-014 |  |  | 12-021F |  |  |  |  |  |  |  |  |  |  |  |  |  |  |  |  |  |  |  |  |  |  |  |  |  |
| 1553001a |  | Prepare Procurements Packages 2011 (BL Compnts) | 184d | 2011-01-05 A | 2011-09-26 A | 9-110M FS+60d | 100% |  |  |  |  |  |  | MECH DES [320 h]; MECH ENG [160 h] | 25,809.6 | 25,809.6 |  |  | 0 | 25809.6 | CHUDAKOV | 1 | 1 | D | 07-024 | H | EUGENE C | 11-006 | 11-026 | 2 | 09-014 | 09-027 | 09-027 |  |  |  | 11-004 |  |  |  |  |  |  |  |  |  |  |  |  |  |  |  |  |  |  |  |  |  |  |
| 1553100 |  | Prepare Environment for Sweep Magnets (BL Compnts) | 130d | 2011-03-01 A | 2011-08-31 A | 9-110M FS+110d | 100% |  |  |  |  |  |  | MECH TECH [400 h] | 17,228 | 17,228 |  |  | 0 | 17228 | CHUDAKOV | 1 | 1 | D |  | H | EUGENE C |  | 11-026 |  |  |  |  | 12-021F |  |  | 11-004 |  |  |  |  |  |  |  |  |  |  |  |  |  |  |  |  |  |  |  |  |  |  |
| 1553031 |  | Develop magnet gap modification | 98d | 2011-08-01 A | 2011-12-19 A | 9-110M FS+204d | 100% |  |  |  |  |  |  | MECH ENG [320 h]; MECH DES [320 h] | 37,326.96 | 37,326.96 |  |  | 0 | 36681.6 | CHUDAKOV | 1 | 1 | D |  | H | EUGENE C | 11-006 | 11-026 |  | 09-014 |  |  | 12-021F |  |  |  |  |  |  |  |  |  |  |  |  |  |  |  |  |  |  |  |  |  |  |  |  |  |
| 1553012E |  | FY12 Travel (BL Compnts) | 247d | 2011-10-03 A | 2012-09-28 A | 1553011E | 100% |  |  |  |  |  |  | TRAVEL | 936 |  | 100 | 100 | 0 | 936 | CHUDAKOV | 1 | 1 | D | 07-024 | E | EUGENE C | 11-006 | 11-026 |  |  |  |  |  | 7.69230769 | 92.3076923 |  |  |  |  |  |  |  |  |  |  |  |  |  |  |  |  |  |  |  |  |  |  |  |
| 1553080 |  | Proc Passive Collimator Sys (BL Compnts) | 127d | 2012-01-09 A | 2012-07-09 A | 9-120M | 100% |  |  |  |  |  |  | PROCUREMENT>$50K 69; PROCUREMENT<$50K 60 | 70,200.35 |  |  |  | 0 | 70200.35 | CHUDAKOV | 1 | 1 | D |  | D | EUGENE C |  | 11-026 |  |  |  |  |  |  |  |  | 0 | 70200.35 | 7020035 | 100 |  |  |  |  |  |  |  |  |  |  |  |  |  |  |  |  |  |  |
| 1553032 |  | Fabricate magnet gap modification | 44d | 2012-01-16 A | 2012-03-19 A | 1553031 | 100% |  | 2012-01-17 | 2012-03-19 |  |  |  | PROCUREMENT<$50K 60 | 12,382.8 |  |  |  | 0 | 12382.8 | CHUDAKOV | 1 | 1 | D |  | D | EUGENE C | 11-006 | 11-026 |  | 09-014 |  |  | 12-021F |  |  |  | 0 | 12382.8 | 1238280 | 100 |  |  |  |  |  |  |  |  |  |  |  |  |  |  |  |  |  |  |
| 1553090 |  | Fabricate Collimator Support (BL Compnts) | 84d | 2012-01-16 A | 2012-05-14 A | 1553085 | 100% |  | 2012-01-17 | 2012-05-14 |  |  |  | PROCUREMENT<$50K 60 | 17,550.09 |  |  |  | 0 | 17550.09 | CHUDAKOV | 1 | 1 | D |  | H | EUGENE C |  | 11-026 |  |  |  |  |  |  |  |  | 0 | 17550.09 | 1755009 | 100 |  |  |  |  |  |  |  |  |  |  |  |  |  |  |  |  |  |  |
| 1553002 |  | Prepare Procurements Packages 2012 (BL Compnts) | 160d | 2012-02-01 A | 2012-09-17 A | 9-120M FS+78d, 1553001a | 100% |  |  |  |  |  |  | MECH ENG [240 h]; MECH DES [480 h] | 39,950.4 | 39,950.4 |  |  | 0 | 39950.4 | CHUDAKOV | 1 | 1 | D | 07-024 | H | EUGENE C | 11-006 | 11-026 | 2 | 09-014 | 09-027 | 09-027 |  |  |  | 11-004 |  |  |  |  |  |  |  |  |  |  |  |  |  |  |  |  |  |  |  |  |  |  |
| 1553034 |  | Develop Pair Spec magnet support | 50d | 2012-02-05 A | 2012-04-16 A | 9-120M | 100% |  | 2012-02-06 | 2012-04-16 |  |  |  | MECH ENG [85.09 h]; MECH DES [102.11 h] | 10,885.16 | 10,885.16 |  |  | 0 | 10885.169452 | CHUDAKOV | 1 | 1 | D |  | H | EUGENE C | 11-006 | 11-026 |  | 09-014 |  |  | 12-021 |  |  |  |  |  |  |  |  |  |  |  |  |  |  |  |  |  |  |  |  |  |  |  |  |  |
| 1553036 |  | Build Pair Spectrometer Vacuum Box Labor (BL Compnts) Labor | 88d | 2012-02-06 A | 2012-06-11 A | 9-120M FS+96d | 100% |  |  |  |  |  |  | MECH TECH [120 h] | 5,332.8 | 5,332.8 |  |  | 0 | 5332.8 | CHUDAKOV | 1 | 1 | D |  | H | EUGENE C | 11-006 | 11-026 |  | 09-014 |  |  | 12-021 |  |  |  |  |  |  |  |  |  |  |  |  |  |  |  |  |  |  |  |  |  |  |  |  |  |
| 1553095 |  | Purchase Lead for Cave Exit Wall (BL Compnts) | 136d | 2012-03-07 A | 2012-09-17 A | 9-120M | 100% |  |  |  |  |  |  | PROCUREMENT<$50K 60 | 58,500.29 |  |  |  | 0 | 58500.29 | CHUDAKOV | 1 | 1 | D |  | H | EUGENE C | 11-006 | 11-026 |  |  |  |  | 12-021F |  |  |  | 0 | 58500.29 | 5850029 | 100 |  |  |  |  |  |  |  |  |  |  |  |  |  |  |  |  |  |  |
| 1553038 |  | Build Pair Spectrometer Vacuum Box (BL Compnts) | 65d | 2012-03-09 A | 2012-06-11 A | 1553036 FS-30d | 100% |  |  |  |  |  |  | PROCUREMENT<$50K 60 | 26,500 |  |  |  | 0 | 26500 | CHUDAKOV | 1 | 1 | D |  | H | EUGENE C | 11-006 | 11-026 |  | 09-014 |  |  | 12-021 |  |  |  | 0 | 26500 | 2650000 | 100 |  |  |  |  |  |  |  |  |  |  |  |  |  |  |  |  |  |  |
| 1553033 |  | Install magnet gap modification | 21d | 2012-03-19 A | 2012-04-16 A | 1553032, 9-120M | 100% |  |  |  |  |  |  | MECH TECH [320 h]; MECH ENG [80 h]; MECH DES [40 h] | 21,757.2 | 21,757.2 |  |  | 0 | 21757.2 | CHUDAKOV | 1 | 1 | D |  | H | EUGENE C | 11-006 | 11-026 |  | 09-014 |  |  | 12-021 |  |  |  |  |  |  |  | 1553033 |  |  |  |  |  |  |  |  |  |  |  |  |  |  |  |  |  |
| 1553048 |  | Proc Pair convertor (BL Compnts) Labor Original | 190d | 2012-04-02 A | 2013-02-11 A | 9-120M FS+125d | 100% |  | 2012-04-02 | 2013-01-07 |  |  |  | MECH DES [33.23 h]; MECH ENG [11.08 h] | 2,402.82 | 2,408.51 |  |  | 0 | 2377.6187 | CHUDAKOV | 1 | 1 | D |  | H | EUGENE C | 11-006 | 11-026 |  |  |  |  | 12-021 |  |  |  |  |  |  |  |  | 12-054F | XX |  |  |  |  |  |  |  |  |  |  |  |  |  |  |  |
| 1553035 |  | Proc Pair Spectrometer Mag Pwr Supply (BL Compnts) | 144d | 2012-07-02 A | 2013-08-30 A | 9-120M FS+150d | 100% |  | 2012-07-02 | 2013-01-31 |  |  |  | PROCUREMENT<$50K 60 NO ESCALATION FY13 | 48,297.85 |  |  |  | 48297.85 | 48297.85 | CHUDAKOV | 1 | 1 | D |  | D | EUGENE C |  | 11-026 |  | 09-014 |  |  | 12-021 |  |  |  | 0 | 48297.85 | 4829785 | 100 |  |  | XX | 08-016 | 09-012 |  |  |  |  |  |  |  |  |  |  |  |  |  |
| 1553040 |  | Proc Pair Spectrometer Detctr's (BL Compnts) Part A | 117d | 2012-07-02 A | 2013-05-13 A | 9-120M FS+163d | 100% |  | 2012-07-02 | 2012-12-14 |  |  |  | PROCUREMENT<$50K 60 NO ESCALATION FY13 | 56,000 |  |  |  | 0 | 56000 | CHUDAKOV | 1 | 1 | D |  | D | EUGENE C |  | 11-026 |  |  |  |  | 12-021 |  |  |  | 0 | 56000 | 5600000 | 100 |  |  | XX |  |  | 12-055 |  |  |  |  |  |  |  |  |  |  |  |  |
| 1553034a |  | Procure Pair Spec magnet support | 84d | 2012-09-03 A | 2013-01-14 A | 1553034, 9-120M FS+200d | 100% |  | 2012-09-04 | 2013-01-09 |  |  |  | PROCUREMENT<$50K 60 | 23,500 |  |  |  | 0 | 23500 | CHUDAKOV | 1 | 1 | D |  | D | EUGENE C | 11-006 | 11-026 |  | 09-014 |  |  | 12-021 |  |  |  | 0 | 23500 | 2350000 | 100 |  |  | XX |  |  |  |  |  |  |  |  |  |  |  |  |  |  |  |
| 1553013E |  | FY13 Travel (BL Compnts) | 248d | 2012-10-01 A | 2013-08-30 A | 1553012E | 100% |  | 2012-10-01 | 2013-09-30 |  |  |  | TRAVEL | 887.97 |  | 100 | 100 | 163.616684 | 887.97 | CHUDAKOV | 1 | 1 | D | 07-024 | E | EUGENE C | 11-006 | 11-026 |  |  |  |  |  | 8.06451612 | 91.93548387 |  |  |  |  |  |  |  |  |  |  |  |  |  |  |  |  |  |  |  |  |  |  |  |
| 1553105 |  | Purchase Slow Control Crate (BL Compnts) | 21d | 2012-10-01 A | 2012-10-29 A | 9-120M FS+165d, 9-130M FS+55d | 100% |  |  |  |  |  |  | PROCUREMENT<$50K 60 | 14,010.82 |  |  |  | 0 | 14010.82 | CHUDAKOV | 1 | 1 | D | 07-024 | H | EUGENE C | 11-006 | 11-026 |  |  |  |  |  |  |  | 11-004 | 0 | 14010.82 | 1401082 | 100 |  |  |  |  |  |  |  |  |  |  |  |  |  |  |  |  |  |  |
| 1553015 |  | Proc Goniometer (BL Compnts) | 87d | 2012-11-05 A | 2013-03-11 A | 9-130M FS+40d | 100% |  | 2012-11-05 | 2013-03-19 |  |  |  | PROCUREMENT>$50K 69; PROCUREMENT<$50K 60 | 169,026.08 |  |  |  | 0 | 169026.08 | CHUDAKOV | 1 | 1 | D |  | D | EUGENE C | 11-006 | 11-026 |  |  |  |  | 12-021 |  |  | 11-004 | 0 | 169026.08 | 16902608 | 100 | 1553015 | 12-054 |  |  |  |  |  |  |  |  |  |  |  |  |  |  |  |  |
| 1553065 |  | Proc Active Collimator Compnts (BL Compnts) | 148d | 2012-11-05 A | 2013-04-15 A | 9-120M FS+184d | 100% |  | 2012-11-05 | 2013-06-13 |  |  |  | PROCUREMENT<$50K 60 | 11,700.06 |  |  |  | 0 | 11700.06 | CHUDAKOV | 1 | 1 | D |  | D | EUGENE C |  | 11-026 |  |  |  |  |  |  |  |  | 0 | 11700.06 | 1170006 | 100 |  |  |  |  |  |  |  |  |  |  |  |  |  |  |  |  |  |  |
| 1553045 |  | Manufacture, Mount and Test Pair Spectrometer Detctr's (BL Compnts) | 73d | 2013-02-04 A | 2013-08-30 A | 1553040 FS-75d, 1553038, 1553036, 1553040a FS-80d | 100% |  | 2013-06-26 | 2013-10-08 |  |  |  | MECH DES [320 h]; MECH ENG [200 h]; MECH TECH [320 h] | 45,172.59 | 45,054.4 |  |  | 22527.2 | 45054.4 | CHUDAKOV | 1 | 1 | D |  | H | EUGENE C | 11-006 | 11-026 |  |  |  |  | 12-021 |  |  |  |  |  |  |  | 1553045 |  |  |  |  |  |  |  |  |  |  |  |  |  |  |  |  |  |
| 1553060 |  | Proc Roughing Pump (BL Compnts) | 130d | 2013-03-04 A | 2013-06-17 A | 9-130M FS+105d | 100% |  | 2013-04-01 | 2013-10-02 |  |  |  | PROCUREMENT<$50K 60 | 6,036.66 |  |  |  | 0 | 6036.66 | CHUDAKOV | 1 | 1 | D |  | D | EUGENE C |  | 11-026 |  |  |  |  |  |  |  |  | 0 | 6036.66 | 603666 | 100 |  | 12-054 |  |  |  |  |  |  |  |  |  |  |  |  |  |  |  |  |
| 1553040a |  | Proc Pair Spectrometer Detctr's (BL Compnts) Part B | 53d | 2013-04-01 A | 2013-08-30 A | 9-130M FS+120d, 9-120M FS+163d | 100% |  | 2013-05-01 | 2013-07-16 |  |  |  | PROCUREMENT<$50K 60 NO ESCALATION FY13 | 9,000 |  |  |  | 2250 | 9000 | CHUDAKOV | 1 | 1 | D |  | D | EUGENE C |  | 11-026 |  |  |  |  | 12-021 |  |  |  | 0 | 9000 | 900000 | 100 |  |  |  |  |  | 12-055 |  |  |  |  |  |  |  |  |  |  |  |  |
| 1553017 |  | Procure vacuum guages and valves for tagger beamline | 59d | 2013-06-01 A | 2013-08-30 A | 9-130M FS+60d | 100% |  | 2013-07-01 | 2013-09-23 |  |  |  | PROCUREMENT<$50K 60 | 12,898.75 |  |  |  | 6449.375 | 12898.75 | CHUDAKOV | 1 | 1 | D |  | D | EUGENE C | 11-006 | 11-026 |  |  |  |  | 12-021 |  |  | 11-004 | 0 | 12898.75 | 1289875 | 100 |  | 12-054 |  |  |  |  |  |  |  |  |  |  |  |  |  |  |  |  |
| 1553048a |  | Proc Pair convertor (BL Compnts) Labor Revised 2012 ETC | 102d | 2013-06-01 A | 2013-08-26 A | 1553048 FS+25d | 100% |  | 2013-07-01 | 2013-11-21 |  |  |  | MECH DES [206.77 h]; MECH ENG [68.92 h] | 15,447.38 | 15,265.59 |  |  | 7396.39065 | 14792.7813 | CHUDAKOV | 1 | 1 | D |  | H | EUGENE C | 11-006 | 11-026 |  |  |  |  | 12-021 |  |  |  |  |  |  |  |  | 12-054F |  |  |  |  |  |  |  |  |  |  |  |  |  |  |  |  |
| 1553020 |  | Write Control Software for Goniometer (BL Compnts) | 62d | 2013-08-01 A | 2013-08-30 A | 1553105, 1553015 | 100% |  | 2013-08-01 | 2013-10-28 |  |  |  | SCIENTIST [360 h] | 26,499.02 | 26,229.6 |  |  | 26229.6 | 26229.6 | CHUDAKOV | 1 | 1 | D |  | H | EUGENE C | 11-006 | 11-026 |  |  |  |  | 12-021 |  |  | 11-004 |  |  |  |  |  | 12-054 |  |  |  |  |  |  |  |  |  |  |  |  |  |  |  |  |
| 1553050 |  | Proc Pair convertor (BL Compnts) | 59d | 2013-08-30 A | 2013-08-30 A | 1553048a FS-125d, 1553048 FS-130d, 9-130M FS+125d | 100% |  | 2013-09-03 | 2013-11-22 |  |  |  | PROCUREMENT<$50K 60 | 17,026.35 |  |  |  | 17026.35 | 17026.35 | CHUDAKOV | 1 | 1 | D |  | D | EUGENE C | 11-006 | 11-026 |  |  |  |  | 12-021 |  |  |  | 0 | 17026.35 | 1702635 | 100 |  | 12-054 |  |  |  |  |  |  |  |  |  |  |  |  |  |  |  |  |
| 1553055 |  | Assemble and Test Pair convertor (BL Compnts) | 64d | 2013-08-30 A | 2013-08-30 A | 1553050 FS+8d | 100% |  | 2013-12-09 | 2014-03-18 |  |  |  | MECH TECH [90 h]; MECH ENG [45 h]; MECH DES [90 h]; SCIENTIST [225 h] | 29,151.45 | 28,251 |  |  | 50224 | 28251 | CHUDAKOV | 1 | 1 | D |  | H | EUGENE C | 11-006 | 11-026 |  |  |  |  | 12-021 |  |  |  |  |  |  |  |  | 12-054 |  |  |  |  |  |  |  |  |  |  |  |  |  |  |  |  |
| 1553070 |  | Assemble Active Collimator (BL Compnts) FY12 | 57d | 2013-08-30 A | 2013-08-30 A | 1553090, 1553065 | 100% |  | 2013-09-03 | 2013-11-20 |  |  |  | PD UNIV STUDNT [280.62 h] | 3,153.38 | 3,089.63 |  |  | 2994.2154 | 2994.2154 | CHUDAKOV | 1 | 1 | D |  | H | EUGENE C |  | 11-026 |  |  |  |  |  |  |  |  |  |  |  |  | 1553070 |  |  |  |  |  | 12-053 |  |  |  |  |  |  |  |  |  |  |  |
| 1553070a |  | Assemble Active Collimator (BL Compnts) FY13 | 73d | 2013-08-30 A | 2013-08-30 A | 1553070 | 100% |  | 2013-11-21 | 2014-03-17 |  |  |  | PD UNIV STUDNT [359.38 h] | 4,082.56 | 3,956.77 |  |  | 3956.7738 | 3956.7738 | CHUDAKOV | 1 | 1 | D |  | H | EUGENE C |  | 11-026 |  |  |  |  |  |  |  |  |  |  |  |  |  |  |  |  |  |  | 12-053 |  |  |  |  |  |  |  |  |  |  |  |
| 1553072 |  | Program & test Collimator Table (BL Components) FY12 | 57d | 2013-08-30 A | 2013-08-30 A | 9-130M FS+125d, 1553080 | 100% |  | 2013-09-03 | 2013-11-20 |  |  |  | VISTNG USERS [111.93 h]; MECH DES [68.4 h]; MECH ENG [24.87 h]; CONTRB UNIV LBR [37.31 h] | 7,587.15 | 7,432.75 |  |  | 7202.3193 | 7202.3193 | CHUDAKOV | 1 | 1 | D |  | H | EUGENE C | 11-006 | 11-026 |  | 09-014 |  |  |  |  |  |  |  |  |  |  |  |  |  |  |  |  | 12-053 |  |  |  |  |  |  |  |  |  |  |  |
| 1553072a |  | Program & test Collimator Table (BL Components) FY13 | 53d | 2013-08-30 A | 2013-08-30 A | 1553072 | 100% |  | 2013-11-21 | 2014-02-14 |  |  |  | VISTNG USERS [104.07 h]; MECH DES [63.6 h]; CONTRB UNIV LBR [34.69 h]; MECH ENG [23.13 h] | 7,132.6 | 6,911.45 |  |  | 6911.4393 | 6911.4393 | CHUDAKOV | 1 | 1 | D |  | H | EUGENE C | 11-006 | 11-026 |  | 09-014 |  |  |  |  |  |  |  |  |  |  |  |  |  |  |  |  | 12-053 |  |  |  |  |  |  |  |  |  |  |  |
| 1553075 |  | Test Active Collimator (BL Compnts) | 65d | 2013-08-30 A | 2013-08-30 A | 1553072a, 1553070a | 100% |  | 2014-03-18 | 2014-06-17 |  |  |  | PD UNIV STUDNT [640 h]; CONTRB UNIV LBR [640 h] | 7,270.4 | 7,046.4 |  |  | 7046.4 | 7046.4 | CHUDAKOV | 1 | 1 | D |  | H | EUGENE C |  | 11-026 |  |  |  |  |  |  |  |  |  |  |  |  |  |  |  |  |  |  |  |  |  |  |  |  |  |  |  |  |  |  |
| 1553110 |  | Re-Baseline Actuals Adjustment | 1d | 2013-08-30 A | 2013-08-30 A |  | 100% |  | 2013-09-03 | 2013-09-03 |  |  |  | PROCUREMENT>$50K 69 NO ESCALATION | -105,527.35 |  |  |  |  |  |  |  |  |  |  |  |  |  |  |  |  |  |  |  |  |  |  |  |  |  | 100 |  |  |  |  |  |  |  | ADJ |  |  |  |  |  |  |  |  |  |  |
| 2553011 |  | Diamond contractor and procurements support (BL Compnts) FY13 | 267d | 2013-09-03 A | 2013-09-30 A | 9-130M FS+228d | 100% |  | 2013-10-01 | 2014-10-28 |  |  | 8/5 M-F w/JLAB Holidays ReBaseline | SCIENTIST [7.19 h]; MECH ENG [2.4 h] | 719.75 | 697.53 | 100 | 100 |  | 0 | CHUDAKOV | 1 | 1 | D |  | E | EUGENE C | 11-006 | 11-026 |  |  |  |  | 12-021 | 92.50936329 | 7.4906367 |  |  |  |  |  |  | 12-054 |  |  |  |  |  |  | 2553011 | 697.52865 | PE | 13-015 | PR |  |  |  |  |  |
| 2553017 |  | Procure vacuum gauges and valves for tagger beamline | 36d | 2013-09-03 A | 2013-11-22 | 9-130M FS+228d | 20% | 16d | 2013-10-01 | 2013-11-19 | 185d | 0d | 8/5 M-F w/JLAB Holidays ReBaseline | PROCUREMENT<$50K 60 NO ESCALATION FY14 | 3,224.69 |  |  |  |  | 644.938 | CHUDAKOV | 1 | 1 | D |  | D | EUGENE C | 11-006 | 11-026 |  |  |  |  | 12-021 |  |  | 11-004 | 2579.752 | 644.938 | 64493.8 | 100 |  | 12-054 |  |  |  |  |  |  | 2553017 |  |  | 13-015 | PR | CP | OB-2 |  |  |  |
| 2553035 |  | Proc Pair Spectrometer Mag Pwr Supply (BL Compnts) | 20d | 2013-09-03 A | 2013-09-23 A | 9-130M FS+228d | 100% |  | 2013-10-01 | 2013-10-28 |  |  | 8/5 M-F w/JLAB Holidays ReBaseline | PROCUREMENT>$50K 69; PROCUREMENT<$50K 60 | 74,300 |  |  |  |  | 0 | CHUDAKOV | 1 | 1 | D |  | D | EUGENE C |  | 11-026 |  | 09-014 |  |  | 12-021 |  |  |  | 0 | 74300 | 7430000 | 100 |  |  |  | 08-016 | 09-012 |  |  |  | 2553035 | 74300 |  | 13-015 | PR | OB | OB | 13-007F |  |  |
| 2553036 |  | Proc Parts for Pair Spectrometer | 20d | 2013-09-03 A | 2013-09-23 A | 9-130M FS+228d | 100% |  | 2013-10-01 | 2013-10-28 |  |  | 8/5 M-F w/JLAB Holidays ReBaseline | PROCUREMENT<$50K 60 | 1,360 |  |  |  |  | 0 | CHUDAKOV | 1 | 1 | D |  | D | EUGENE C |  | 11-026 |  | 09-014 |  |  | 12-021 |  |  |  | 0 | 1360 | 136000 | 100 |  |  |  | 08-016 | 09-012 |  |  |  | 2553036 | 1360 |  | 13-015 | PR | VQ | OB-2 | 13-007F |  |  |
| 2553041 |  | Build PS low granularity Support Frame | 21d | 2013-09-03 A | 2013-09-23 A | 2553036 FS-20d | 100% |  | 2013-10-01 | 2013-10-29 |  |  | 8/5 M-F w/JLAB Holidays ReBaseline | PROCUREMENT<$50K 60 NO ESCALATION FY14 | 620 |  |  |  |  | 0 | CHUDAKOV | 1 | 1 | D |  | D | EUGENE C |  | 11-026 |  |  |  |  | 12-021 |  |  |  | 0 | 620 | 62000 | 100 |  |  |  |  |  | 12-055 |  |  | 2553041 | 620 |  | 13-015 | PR | PE | OB-2 | 13-007F |  |  |
| 2553042 |  | Fabricate PS High Granularity Counters | 20d | 2013-09-03 A | 2013-12-02 | 9-130M FS+228d | 60% | 20d | 2013-10-01 | 2013-10-28 | 170d | 0d | 8/5 M-F w/JLAB Holidays ReBaseline | MECH TECH [128 h]; SCIENTIST [24 h] | 7,861.28 | 3,809.36 |  |  |  | 1523.744 | CHUDAKOV | 1 | 1 | D |  | S | EUGENE C |  | 11-026 |  |  |  |  | 12-021 |  |  |  |  |  |  |  |  |  |  |  |  | 12-055 |  |  | 2553042 | 3047.488 | PE | 13-015 | PR |  |  | 13-007F | ST |  |
| 2553050 |  | Proc Pair convertor insertion device (BL Compnts) (Previously Obligated) | 51d | 2013-09-03 A | 2013-09-23 A | 9-130M FS+228d | 100% |  | 2013-10-01 | 2013-12-12 |  |  | 8/5 M-F w/JLAB Holidays ReBaseline | PROCUREMENT<$50K 60 NO ESCALATION FY14 | 13,324.8 |  |  |  |  | 0 | CHUDAKOV | 1 | 1 | D |  | D | EUGENE C | 11-006 | 11-026 |  |  |  |  | 12-021 |  |  |  | 0 | 13324.8 | 1332480 | 100 |  | 12-054 |  |  |  |  |  |  | 2553050 | 13324.8 |  | 13-015 | PR | PE | OB | 13-007F |  |  |
| 2553062 |  | UConn Contract - Procure Readout Electronics for Active Collimator | 40d | 2013-09-03 A | 2013-12-02 | 9-130M FS+228d |  | 20d | 2013-10-01 | 2013-11-25 | 142d | 20d | 8/5 M-F w/JLAB Holidays ReBaseline | PROCUREMENT>$50K 69 NO ESCALATION | 6,000.18 |  |  |  |  | 0 | CHUDAKOV | 1 | 1 | D |  | D | EUGENE C |  | 11-026 |  |  |  |  |  |  |  |  | 6000.18 | 0 | 0 | 100 |  | 12-054 |  |  |  |  |  |  | 2553062 |  |  | 13-015 | PR | OB | OB |  |  |  |
| 2553063 |  | UConn Contract - Assembly and Test of Active Collimator | 77d | 2013-09-03 A | 2013-12-20 | 2553062 FS-40d |  | 34d | 2013-10-01 | 2014-01-30 | 193d | 43d | 8/5 M-F w/JLAB Holidays ReBaseline | PROCUREMENT>$50K 69 NO ESCALATION | 6,192 |  |  |  |  | 0 | CHUDAKOV | 1 | 1 | D |  | D | EUGENE C |  | 11-026 |  |  |  |  |  |  |  |  | 6192 | 0 | 0 | 100 |  | 12-054 |  |  |  |  |  |  | 2553063 |  |  | 13-015 | PR | OB | OB |  |  |  |
| 2553064 |  | UConn Contract - Delivery of Active Collimator to JLab | 77d | 2013-09-03 A | 2013-12-20 | 2553063 FS-77d |  | 34d | 2013-10-01 | 2014-01-30 | 150d | 149d | 8/5 M-F w/JLAB Holidays ReBaseline | PROCUREMENT>$50K 69 NO ESCALATION | 679 |  |  |  |  | 0 | CHUDAKOV | 1 | 1 | D |  | D | EUGENE C |  | 11-026 |  |  |  |  |  |  |  |  | 679 | 0 | 0 | 100 |  | 12-054 |  |  |  |  |  |  | 2553064 |  |  | 13-015 | PR | OB | OB |  |  |  |
| 2553110 |  | Manufacturing Drawings for Goniometer vacuum chamber | 20d | 2013-09-03 A | 2013-09-23 A | 9-130M FS+228d | 100% |  | 2013-10-01 | 2013-10-28 |  |  | 8/5 M-F w/JLAB Holidays ReBaseline | MECH ENG [11.2 h]; MECH DES [16.8 h] | 1,698.14 | 1,645.56 |  |  |  | 0 | CHUDAKOV | 1 | 1 | D |  | S | EUGENE C |  |  |  |  |  |  |  |  |  |  |  |  |  |  |  |  |  |  |  |  |  |  | 2553110 | 1645.56 | PE | 13-015 | PR |  |  | 13-007 | ST |  |
| 2553140 |  | Manufacturing Drawings of Amorphous target insertion device (E-beam) FY13 | 53d | 2013-09-03 A | 2013-10-21 A | 9-130M FS+228d | 100% |  | 2013-10-01 | 2013-12-16 |  |  | 8/5 M-F w/JLAB Holidays ReBaseline | MECH ENG [7.55 h]; MECH DES [22.64 h] | 1,725.13 | 1,714.7 |  |  |  | 334.339155 | CHUDAKOV | 1 | 1 | D |  | S | EUGENE C |  |  |  |  |  |  |  |  |  |  |  |  |  |  |  |  |  |  |  |  |  |  | 2553140 | 1337.35662 | PE | 13-015 | PR |  |  | 13-007 | ST |  |
| 2553140a |  | Manufacturing Drawings of Amorphous target insertion device (E-beam) FY14 | 33d | 2013-09-03 A | 2013-10-21 A | 2553140 FS-40d | 100% |  | 2013-10-01 | 2013-11-14 |  |  | 8/5 M-F w/JLAB Holidays ReBaseline | MECH ENG [12.45 h]; MECH DES [37.36 h] | 2,846.27 | 2,823.07 |  |  |  | 569.25358499 | CHUDAKOV | 1 | 1 | D |  | S | EUGENE C |  |  |  |  |  |  |  |  |  |  |  |  |  |  |  |  |  |  |  |  |  |  | 2553140 | 2277.01434 | PE | 13-015 | PR |  |  | 13-007 | ST | 14-001 |
| 2553145 |  | Fab Amorphous insertion device (e-beam) (Previously Obligated) | 70d | 2013-09-03 A | 2013-09-23 A | 2553140a FS-53d, 2553140 FS-53d | 100% |  | 2014-09-03 | 2014-12-11 |  |  | 8/5 M-F w/JLAB Holidays ReBaseline | PROCUREMENT<$50K 60 NO ESCALATION FY14 | 15,066 |  |  |  |  | 0 | CHUDAKOV | 1 | 1 | D |  | D | EUGENE C |  |  |  |  |  |  |  |  |  |  | 0 | 15066 | 1506600 | 100 |  |  |  |  |  |  |  |  | 2553145 | 15066 |  | 13-015 | PR | PE | OB | 13-007 |  |  |
| 2553147 |  | Fab Amorphous insertion device (e-beam) | 70d | 2013-09-03 A | 2013-12-11 | 2553140a FS-53d, 2553140 FS-53d | 40% | 27d | 2013-10-01 | 2014-01-21 | 117d | 99d | 8/5 M-F w/JLAB Holidays ReBaseline | PROCUREMENT<$50K 60 NO ESCALATION FY14 | 4,344 |  |  |  |  | 1737.6 | CHUDAKOV | 1 | 1 | D |  | D | EUGENE C |  |  |  |  |  |  |  |  |  |  | 2606.4 | 1737.6 | 173760 | 100 |  |  |  |  |  |  |  |  | 2553145 |  |  | 13-015 | PR | PE | OB-2 | 13-007 |  |  |
| 2553170 |  | Procure goniometer vacuum pump/instrumentation | 73d | 2013-09-03 A | 2013-12-16 | 9-130M FS+228d |  | 30d | 2013-10-01 | 2014-01-24 | 154d | 136d | 8/5 M-F w/JLAB Holidays ReBaseline | PROCUREMENT<$50K 60 NO ESCALATION FY14 | 5,238 |  |  |  |  | 0 | CHUDAKOV | 1 | 1 | D |  | D | EUGENE C |  |  |  |  |  |  |  |  |  |  | 5238 | 0 | 0 | 100 |  |  |  |  |  |  |  |  | 2553170 |  |  | 13-015 | PR | CP | OB-2 | 13-007 |  |  |
| 2553175 |  | Fab Tagger beamline components | 20d | 2013-09-03 A | 2013-09-23 A | 9-130M FS+228d | 100% |  | 2013-10-01 | 2013-10-28 |  |  | 8/5 M-F w/JLAB Holidays ReBaseline | MECH TECH [36 h] | 1,703.52 | 1,650.96 |  |  |  | 0 | CHUDAKOV | 1 | 1 | D |  | S | EUGENE C |  |  |  |  |  |  |  |  |  |  |  |  |  |  |  |  |  |  |  |  |  |  | 2553175 | 1650.96 | PE | 13-015 | PR |  |  | 13-007 | ST |  |
| 2553055 |  | Assemble and Test Pair convertor (BL Compnts) | 70d | 2013-09-09 A | 2014-01-21 | 2553050, 2553052 FS-60d | 23% | 47d | 2014-01-07 | 2014-04-15 | 148d | 0d | 8/5 M-F w/JLAB Holidays ReBaseline | MECH TECH [160 h]; MECH ENG [80 h]; MECH DES [160 h]; SCIENTIST [40 h] | 24,760 | 11,085.94 |  |  |  | 0 | CHUDAKOV | 1 | 1 | D |  | S | EUGENE C | 11-006 | 11-026 |  |  |  |  | 12-021 |  |  |  |  |  |  |  |  | 12-054 |  |  |  |  |  |  | 2553055 | 5694.8 | PE | 13-015 | PR |  |  | 13-007 | ST | 14-001 |
| 2553011a |  | Diamond contractor and procurements support (BL Compnts) FY14 | 247d | 2013-10-01 A | 2014-09-30 | 2553011 | 9% | 224d | 2013-11-01 | 2014-10-31 | 0d |  | 8/5 M-F w/JLAB Holidays ReBaseline | SCIENTIST [88.81 h]; MECH ENG [29.6 h] | 8,886.97 | 827.53 | 100 | 100 |  | 827.37658347 | CHUDAKOV | 1 | 1 | D |  | E | EUGENE C | 11-006 | 11-026 |  |  |  |  | 12-021 | 90.6882591 | 9.31174089 |  |  |  |  |  |  | 12-054 |  |  |  |  |  |  | 2553011 |  | PE | 13-015 | PR |  |  |  |  | 14-001 |
| 2553052 |  | Proc Pair convertor insertion device Mods (BL Compnts) | 51d | 2013-10-01 A | 2013-10-21 A | 9-130M FS+228d | 100% |  | 2013-11-01 | 2014-01-27 |  |  | 8/5 M-F w/JLAB Holidays ReBaseline | PROCUREMENT<$50K 60 NO ESCALATION FY14 | 3,702.35 |  |  |  |  | 3702.35 | CHUDAKOV | 1 | 1 | D |  | D | EUGENE C | 11-006 | 11-026 |  |  |  |  | 12-021 |  |  |  | 0 | 3702.35 | 370235 | 100 |  | 12-054 |  |  |  |  |  |  | 2553050 |  |  | 13-015 | PR | PE | OB-2 | 13-007F |  |  |
| 2553130 |  | Manufacturing Drawings of cooling system for PS detector | 48d | 2013-10-01 A | 2013-12-12 | 9-140M FS+3d | 19% | 28d | 2013-11-01 | 2014-01-22 | 137d | 0d | 8/5 M-F w/JLAB Holidays ReBaseline | MECH ENG [112.8 h]; MECH DES [206.8 h] | 19,031.62 | 8,582.89 |  |  |  | 3616.00704 | CHUDAKOV | 1 | 1 | D |  | S | EUGENE C |  |  |  |  |  |  |  |  |  |  |  |  |  |  |  |  |  |  |  |  |  |  | 2553130 |  | PE | 13-015 | PR |  |  | 13-007 | ST | 14-001 |
| 2553020 |  | Write Control Software for Goniometer (BL Compnts) | 125d | 2013-10-02 A | 2014-05-09 | 9-140M | 75% | 125d | 2013-12-02 | 2014-06-06 | 46d | 28d | 8/5 M-F w/JLAB Holidays ReBaseline | SCIENTIST [320 h] | 24,057.6 | 3,600.46 |  |  |  | 18043.2 | CHUDAKOV | 1 | 1 | D |  | S | EUGENE C | 11-006 | 11-026 |  |  |  |  | 12-021 |  |  | 11-004 |  |  |  |  |  | 12-054 |  |  |  |  |  |  | 2553020 |  | EJ | 13-015 | PR |  |  |  | ST | 14-001 |
| 2553016 |  | Build Vacuum Housing for Goniometer (BL Compnts) | 58d | 2013-10-07 A | 2014-02-05 | 9-140M, 2553110 |  | 58d | 2013-11-04 | 2014-02-06 | 72d | 54d | 8/5 M-F w/JLAB Holidays ReBaseline | PROCUREMENT<$50K 60 | 24,916.85 |  |  |  |  | 0 | CHUDAKOV | 1 | 1 | D |  | D | EUGENE C | 11-006 | 11-026 |  |  | 09-027 | 09-027 | 12-021 |  |  | 11-004 | 24916.85 | 0 | 0 | 100 |  | 12-054 |  | 08-016 | 09-012 |  |  |  | 2553016 |  |  | 13-015 | PR | PE | OB-2 | 13-007 |  | 14-001 |
| 2553044 |  | Build PS High granularity Support Frame | 55d | 2013-11-01 | 2014-01-31 | 9-140M FS+2d |  |  |  |  | 134d | 23d | 8/5 M-F w/JLAB Holidays ReBaseline | PROCUREMENT<$50K 60 | 5,758 |  |  |  |  | 0 | CHUDAKOV | 1 | 1 | D |  | D | EUGENE C |  | 11-026 |  |  |  |  | 12-021 |  |  |  | 5758 | 0 | 0 | 100 |  |  |  |  |  | 12-055 |  |  | 2553044 |  |  | 13-015 | PR | PE |  | 13-007F |  | 14-001 |
| 2553057 |  | Scientific support for Pair spectrometer characterization(BL Compnts) FY13 | 1d | 2013-11-01 | 2013-11-01 | 2553052 FS-32d, 2553050 FS-32d |  |  |  |  | 167d | 0d | 8/5 M-F w/JLAB Holidays ReBaseline | SCIENTIST [2.06 h] | 154.87 |  |  |  |  | 0 | CHUDAKOV | 1 | 1 | D |  | S | EUGENE C | 11-006 | 11-026 |  |  |  |  | 12-021 |  |  |  |  |  |  |  |  | 12-054 |  |  |  |  |  |  | 2553057 |  | PE | 13-015 | PR |  |  | 13-007 |  |  |
| 2553072a |  | Program & test Collimator Table (BL Components) FY13 | 20d | 2013-11-01 | 2013-12-02 | 9-130M FS+228d |  |  |  |  | 113d | 0d | 8/5 M-F w/JLAB Holidays ReBaseline | SCIENTIST [22.53 h]; ELEC ENG [11.27 h] | 2,540.52 |  |  |  |  | 0 | CHUDAKOV | 1 | 1 | D |  | S | EUGENE C | 11-006 | 11-026 |  | 09-014 |  |  |  |  |  |  |  |  |  |  |  |  |  |  |  |  | 12-053 |  | 2553072a |  | EJ | 13-015 | PR |  |  |  |  |  |
| 2553095 |  | Design Install Feedback System for Active Collimator (Accelerator Grp) FY13 | 20d | 2013-11-01 | 2013-12-02 | 2553064 FS-187d, 9-130M FS+228d |  |  |  |  | 1d | 0d | 8/5 M-F w/JLAB Holidays ReBaseline | ELEC TECH [69.95 h]; ELEC ENG [19.67 h] | 4,764.83 |  |  |  |  | 0 | CHUDAKOV | 1 | 1 | D |  | S | EUGENE C |  | 11-026 |  |  |  |  |  |  |  |  |  |  |  |  |  |  |  |  |  |  |  |  | 2553095 |  | EJ | 13-015 | PR |  |  |  |  |  |
| 2553057a |  | Scientific support for Pair spectrometer characterization(BL Compnts) FY14 | 154d | 2013-11-04 | 2014-06-23 | 2553057 |  |  |  |  | 167d | 20d | 8/5 M-F w/JLAB Holidays ReBaseline | SCIENTIST [317.94 h] | 23,902.73 |  |  |  |  | 0 | CHUDAKOV | 1 | 1 | D |  | S | EUGENE C | 11-006 | 11-026 |  |  |  |  | 12-021 |  |  |  |  |  |  |  |  | 12-054 |  |  |  |  |  |  | 2553057 |  | PE | 13-015 | PR |  |  | 13-007 |  | 14-001 |
| 2553185 |  | Manufacturing Drawings of Photon beamline to dump | 21d | 2013-11-26 | 2014-01-07 | 9-140M FS+40d |  |  |  |  | 133d | 0d | 8/5 M-F w/JLAB Holidays ReBaseline | MECH ENG [120 h]; MECH DES [160 h] | 17,168.4 |  |  |  |  | 0 | CHUDAKOV | 1 | 1 | D |  | S | EUGENE C |  |  |  |  |  |  |  |  |  |  |  |  |  |  |  |  |  |  |  |  |  |  | 2553185 |  | PE | 13-015 | PR |  |  | 13-007 | ST | 14-001 |

Notes:
- 2553042: Steps: ___fabricate_counters (done); ___mount_electronics
- 2553110: Steps: Manufacturing Drawings for Goniometer vacuum chamber (done)
- 2553140: Steps: Check Drawings (done); Release drawing package (done); Issue procurment (done)
- 2553140a: Steps: Check Drawings (done); Release drawing package (done); Issue procurment (done)
- 2553175: Steps: Fab Tagger beamline components (done)
- 2553055: Steps: release assy drawings (done); Assemble mechanical components; hook up electrical; align and fiducialize; Test systems
- 2553130: Steps: 3D model (done); structural/pressure system analysis; Make Drawings; Check Drawings; Release drawing package; Issue procurment
- 2553020: Steps: Install laser test setup for goniometer (done); Verify specs; perform test and calibrations (done); Document results
- 2553185: Steps: Finalize requirements; 3D model; structural/pressure system analysis; Make Drawings; Check Drawings; Release drawing package; Issue procurment

| ID | Activity | Duration | Start | Finish | Predecessors | Total float | Free float | Calendar | Resources | Cost | Original Activity ID Rebaseline | Remaining Material Cost Based on % Compl | Claimed Material Cost Based on % Complet | Initial Claimed Material Calc | Claimed Material Divider | MONTHLY EV COST | RESP - Responsibility | STRT%COMP for CM EVM | FNSH%COMP for CM EVM | HALL D Related Milestones | EVMS Reporting Codes | CAM RESPONSIBLE | CR 13-007 | BOE Procurement | CR 13-015 | Post Rebaseline | CR 14-001 | CR 09-014 | CR 11-006 | CR 11-026 | CR 12-053 | BOE Labor | CR 12-021 | CR 12-054 | Activities with Steps | BOE Expenses | CR 11-004 |
| --- | --- | --- | --- | --- | --- | --- | --- | --- | --- | --- | --- | --- | --- | --- | --- | --- | --- | --- | --- | --- | --- | --- | --- | --- | --- | --- | --- | --- | --- | --- | --- | --- | --- | --- | --- | --- | --- |
| 2553190 | Fabricate photon beamline to dump | 29d | 2013-12-02 | 2014-01-22 | 2553185 FS-19d | 133d | 0d | 8/5 M-F w/JLAB Holidays ReBaseline | PROCUREMENT<$50K 60 | 12,589.18 | 2553190 | 12589.18 | 0 | 0 | 100 | 0 | CHUDAKOV | 1 | 1 | D | D | EUGENE C | 13-007 | EJ | 13-015 | PR | 14-001 |  |  |  |  |  |  |  |  |  |  |
| 2553072b | Program & test Collimator Table (BL Components) FY14 | 51d | 2013-12-03 | 2014-02-24 | 2553072a | 113d | 112d | 8/5 M-F w/JLAB Holidays ReBaseline | SCIENTIST [57.47 h]; ELEC ENG [28.73 h] | 6,479.08 | 2553072a |  |  |  |  | 0 | CHUDAKOV | 1 | 1 | D | S | EUGENE C |  |  | 13-015 | PR | 14-001 | 09-014 | 11-006 | 11-026 | 12-053 | EJ |  |  |  |  |  |
| 2553080 | Proc Active Collimator Control Equipment (HallD) | 142d | 2013-12-03 | 2014-07-02 | 9-140M FS+43d, 9-130M FS+228d | 22d | 21d | 8/5 M-F w/JLAB Holidays ReBaseline | PROCUREMENT<$50K 60 NO ESCALATION FY14 | 15,624 | 2553080 | 15624 | 0 | 0 | 100 | 0 | CHUDAKOV | 1 | 1 | D | D | EUGENE C |  | EJ | 13-015 | PR |  |  |  | 11-026 |  |  |  |  |  |  |  |
| 2553090 | Proc Hardware for Active Collimator Control (Accelerator Grp) | 120d | 2013-12-03 | 2014-06-02 | 9-140M FS+43d, 9-130M FS+228d | 44d | 43d | 8/5 M-F w/JLAB Holidays ReBaseline | PROCUREMENT<$50K 60 NO ESCALATION FY14 | 18,800 | 2553090 | 18800 | 0 | 0 | 100 | 0 | CHUDAKOV | 1 | 1 | D | D | EUGENE C |  | EJ | 13-015 | PR |  |  |  | 11-026 |  |  |  |  |  |  |  |
| 2553095a | Design Install Feedback System for Active Collimator (Accelerator Grp) FY14 | 163d | 2013-12-03 | 2014-08-01 | 2553095 | 1d | 0d | 8/5 M-F w/JLAB Holidays ReBaseline | ELEC TECH [570.05 h]; ELEC ENG [160.33 h] | 38,832.17 | 2553095 |  |  |  |  | 0 | CHUDAKOV | 1 | 1 | D | S | EUGENE C |  |  | 13-015 | PR | 14-001 |  |  | 11-026 |  | EJ |  |  |  |  |  |
| 2553005 | Proc Raw Radiator Diamond Crystals (BL Compnts) | 174d | 2013-12-05 | 2014-08-20 | 9-140M FS+45d | 377d | 0d | 8/5 M-F w/JLAB Holidays ReBaseline | PROCUREMENT<$50K 60 | 38,634.34 | 2553005 | 38634.34 | 0 | 0 | 100 | 0 | CHUDAKOV | 1 | 1 | D | D | EUGENE C |  | EV | 13-015 | PR | 14-001 |  | 11-006 | 11-026 |  |  | 12-021 | 12-054 |  |  |  |
| 2553010 | Thinning-Characterization-Mounting of Radiator Diamond Crystals (BL Compnts) Phase 1 | 202d | 2013-12-05 | 2014-09-30 | 2553005 FS-174d | 377d | 0d | 8/5 M-F w/JLAB Holidays ReBaseline | PROCUREMENT<$50K 60; PROCUREMENT>$50K 69 | 55,206.65 | 2553010 | 55206.65 | 0 | 0 | 100 | 0 | CHUDAKOV | 1 | 1 | D | D | EUGENE C |  | EV | 13-015 | PR | 14-001 |  | 11-006 | 11-026 |  |  | 12-021 | 12-054 |  |  |  |
| 2553160 | Manufacturing Drawings of radiator holder | 34d | 2013-12-05 | 2014-02-03 | 9-140M FS+45d | 18d | 0d | 8/5 M-F w/JLAB Holidays ReBaseline | MECH ENG [80 h]; MECH DES [160 h] | 14,181.6 | 2553160 |  |  |  |  | 0 | CHUDAKOV | 1 | 1 | D | S | EUGENE C | 13-007 |  | 13-015 | PR | 14-001 |  |  |  |  | EJ |  |  |  |  |  |
| 2553135 | Procure cooling system for PS detector | 44d | 2013-12-12 | 2014-02-24 | 2553130 FS-1d | 137d | 26d | 8/5 M-F w/JLAB Holidays ReBaseline | PROCUREMENT<$50K 60 | 5,778.64 | 2553135 | 5778.64 | 0 | 0 | 100 | 0 | CHUDAKOV | 1 | 1 | D | D | EUGENE C | 13-007 | EJ | 13-015 | PR | 14-001 |  |  |  |  |  |  |  |  |  |  |
| 2553150 | Manufacturing Drawings of polarimeter vacuum chamber | 49d | 2013-12-16 | 2014-03-05 | 9-140M FS+52d | 81d | 0d | 8/5 M-F w/JLAB Holidays ReBaseline | MECH ENG [120 h]; MECH DES [240 h] | 21,272.4 | 2553150 |  |  |  |  | 0 | CHUDAKOV | 1 | 1 | D | S | EUGENE C | 13-007 |  | 13-015 | PR | 14-001 |  |  |  |  | PE |  |  | ST |  |  |
| 2553085 | Support Control Active Collimator (HallD) FY13 | 20d | 2014-01-03 | 2014-01-31 | 9-130M FS+228d, 9-140M FS+60d | 20d | 0d | 8/5 M-F w/JLAB Holidays ReBaseline | SCIENTIST [7.73 h]; MECH ENG [3.86 h] | 869.37 | 2553085 |  |  |  |  | 0 | CHUDAKOV | 1 | 1 | D | S | EUGENE C |  |  | 13-015 | PR |  |  |  | 11-026 |  | EJ |  |  |  |  |  |
| 2553125 | Install mounting frame for low granularity PS detectors | 43d | 2014-01-03 | 2014-03-05 | 2553041 FS+13d, 9-140M FS+60d | 111d | 0d | 8/5 M-F w/JLAB Holidays ReBaseline | MECH TECH [139.2 h]; SUPPLIES & MATERIALS; MECH ENG [3.48 h]; MECH DES [3.48 h] | 7,115.09 | 2553125 |  |  |  |  | 0 | CHUDAKOV | 1 | 1 | D | S | EUGENE C | 13-007 |  | 13-015 | PR | 14-001 |  |  |  |  | PE |  |  | ST | EJ |  |
| 2553195 | Install photon beamline to dump | 39d | 2014-01-29 | 2014-03-24 | 2553190 FS+4d | 133d | 115d | 8/5 M-F w/JLAB Holidays ReBaseline | MECH TECH [200 h]; SUPPLIES & MATERIALS; MECH ENG [4 h]; MECH DES [4 h] | 10,071.07 | 2553195 |  |  |  |  | 0 | CHUDAKOV | 1 | 1 | D | S | EUGENE C | 13-007 |  | 13-015 | PR | 14-001 |  |  |  |  | PE |  |  | ST | EJ |  |
| 2553085a | Support Control Active Collimator (HallD) FY14 | 109d | 2014-02-03 | 2014-07-07 | 2553085 | 20d | 19d | 8/5 M-F w/JLAB Holidays ReBaseline | SCIENTIST [72.27 h]; MECH ENG [36.14 h] | 8,131.83 | 2553085 |  |  |  |  | 0 | CHUDAKOV | 1 | 1 | D | S | EUGENE C |  |  | 13-015 | PR | 14-001 |  |  | 11-026 |  | EJ |  |  |  |  |  |
| 2553200 | Manufacturing Drawings of Total Absorption Counter | 24d | 2014-02-03 | 2014-03-06 | 9-140M FS+80d | 37d | 0d | 8/5 M-F w/JLAB Holidays ReBaseline | MECH ENG [120 h]; MECH DES [200 h] | 19,220.4 | 2553200 |  |  |  |  | 0 | CHUDAKOV | 1 | 1 | D | S | EUGENE C | 13-007 |  | 13-015 | PR | 14-001 |  |  |  |  | PE |  |  | ST |  |  |
| 2553165 | Fab radiator holder | 31d | 2014-02-05 | 2014-03-19 | 9-140M FS+70d, 2553160 FS+1d | 18d | 0d | 8/5 M-F w/JLAB Holidays ReBaseline | PROCUREMENT<$50K 60 | 3,714.84 | 2553165 | 3714.84 | 0 | 0 | 100 | 0 | CHUDAKOV | 1 | 1 | D | D | EUGENE C | 13-007 | PE | 13-015 | PR | 14-001 |  |  |  |  |  |  |  |  |  |  |
| 2553155 | Fab polarimeter vacuum chamber | 5d | 2014-03-18 | 2014-03-24 | 2553150 FS+8d | 81d | 0d | 8/5 M-F w/JLAB Holidays ReBaseline | PROCUREMENT<$50K 60 | 6,088.21 | 2553155 | 6088.21 | 0 | 0 | 100 | 0 | CHUDAKOV | 1 | 1 | D | D | EUGENE C | 13-007 | EJ | 13-015 | PR | 14-001 |  |  |  |  |  |  |  |  |  |  |
| 2553157 | Install polarimeter | 52d | 2014-03-25 | 2014-06-05 | 2553155 | 81d |  | 8/5 M-F w/JLAB Holidays ReBaseline | MECH ENG [20 h]; MECH TECH [80 h]; SCIENTIST [20 h]; SUPPLIES & MATERIALS | 6,988.98 | 2553157 |  |  |  |  | 0 | CHUDAKOV | 1 | 1 | D | S | EUGENE C | 13-007 |  | 13-015 | PR | 14-001 |  |  |  |  | EJ |  |  | ST | EJ |  |
| 2553205 | Fabricate Total Absorption Counter Support | 64d | 2014-03-31 | 2014-06-27 | 2553200 FS+16d | 37d | 0d | 8/5 M-F w/JLAB Holidays ReBaseline | PROCUREMENT<$50K 60 | 6,500.97 | 2553205 | 6500.97 | 0 | 0 | 100 | 0 | CHUDAKOV | 1 | 1 | D | S | EUGENE C | 13-007 | EJ | 13-015 | PR | 14-001 |  |  |  |  |  |  |  |  |  |  |
| 2553027 | Install Goniometer (BL Compnts) | 41d | 2014-04-23 | 2014-06-19 | 2553020 FS-41d, 2553016 FF, 2553016, 282453000 FS-94d | 18d | 0d | 8/5 M-F w/JLAB Holidays ReBaseline | SCIENTIST [320 h]; MECH TECH [160 h]; MECH ENG [40 h]; MECH DES [80 h] | 38,719.6 | 2553027 |  |  |  |  | 0 | CHUDAKOV | 1 | 1 | D | S | EUGENE C | 13-007 |  | 13-015 | PR | 14-001 |  | 11-006 | 11-026 |  | EJ | 12-021 | 12-054 | ST |  | 11-004 |
| 2553029 | Survey Goniometer (BL Compnts) | 53d | 2014-06-20 | 2014-09-04 | 2553027 | 18d |  | 8/5 M-F w/JLAB Holidays ReBaseline | SCIENTIST [240 h]; MECH TECH [80 h]; MECH ENG [120 h] | 30,789.2 | 2553029 |  |  |  |  | 0 | CHUDAKOV | 1 | 1 | D | S | EUGENE C | 13-007 |  | 13-015 | PR | 14-001 |  | 11-006 | 11-026 |  | PE | 12-021 | 12-054 |  |  | 11-004 |
| 2553210 | Install Total Absorption Counter | 28d | 2014-06-30 | 2014-08-07 | 2553205 | 37d |  | 8/5 M-F w/JLAB Holidays ReBaseline | MECH TECH [120 h]; SUPPLIES & MATERIALS; MECH ENG [60 h]; COMP SCIENT; MECH DES [8 h] | 10,672.19 | 2553210 |  |  |  |  | 0 | CHUDAKOV | 1 | 1 | D | S | EUGENE C | 13-007 |  | 13-015 | PR | 14-001 |  |  |  |  | EJ |  |  | ST | EJ |  |
| 2553075 | Test Active Collimator (BL Compnts) | 40d | 2014-08-04 | 2014-09-29 | 2553080, 2553072b, 2553095, 2553095a, 2553072a, 2553085, 2553090, 2553062 FS+22d, 2553085a, 2553064 | 1d |  | 8/5 M-F w/JLAB Holidays ReBaseline | SCIENTIST [40 h]; PD UNIV STUDNT [320 h]; CONTRB UNIV LBR [320 h] | 6,642.4 | 2553075 |  |  |  |  | 0 | CHUDAKOV | 1 | 1 | D | S | EUGENE C |  |  | 13-015 | PR | 14-001 |  |  | 11-026 |  | EJ |  |  |  |  |  |
| 2553010a | Thinning-Characterization-Mounting of Radiator Diamond Crystals (BL Compnts) | 120d | 2014-10-01 | 2015-04-01 | 2553010 | 377d | 0d | 8/5 M-F w/JLAB Holidays ReBaseline | PROCUREMENT<$50K 60 | 30,957 | 2553010a | 30957 | 0 | 0 | 100 | 0 | CHUDAKOV | 1 | 1 | D | D | EUGENE C |  | EV | 13-015 | PR | 14-001 |  | 11-006 | 11-026 |  |  | 12-021 | 12-054 |  |  |  |

Notes:
- 2553150: Steps: Finalize requirements; 3D model; structural/pressure system analysis; Make Drawings; Check Drawings; Release drawing package; Issue procurment
- 2553125: Steps: drill/tap platform; install frame onto platform; Survey and align (initial)
- 2553195: Steps: drill/tap platform/wall/recks; attach supports to stand/wall/racks; install beamline; leak check; Survey and align (initial)
- 2553200: Steps: Finalize requirements; 3D model; structural analysis; Make Drawings; Check Drawings; Release drawing package; Issue procurment
- 2553157: Steps: drill/tap platform/wall; attach supports to stand/wall; install device; Survey and align (initial); check counter operation
- 2553027: Steps: install stand (S&A); install baseplate and goni; install bell and leak check
- 2553210: Steps: drill/tap platform/wall; attach supports to stand/wall; installcounter; Survey and align (initial); check counter operation

| ID | WBS | Activity | Type | Duration | Start | Finish | Predecessors | Complete | Planned start | Planned finish | Total float | Free float | Calendar | Resources | Cost | Actual cost | Remaining Material Cost Based on % Compl | Claimed Material Cost Based on % Complet | Initial Claimed Material Calc | Claimed Material Divider | Calculated Remaining Total Cost | MONTHLY EV COST | RESP - Responsibility | STRT%COMP for CM EVM | FNSH%COMP for CM EVM | HALL D Related Milestones | CR 07-024 | EVMS Reporting Codes | CAM RESPONSIBLE | CR 09-043 | CR 11-006 | CR 11-026 | CR 12-021 | CR 12-054 | CR 11-001 | 12 GeV 1st level Critical Path | CR 12-053 | CR 09-014 | CR 09-027 | CR 09-027 Repair | CR 11-054 | Milestone Level | CR 10-042 | Specification | CR 09-012 | ReBaseline Actuals Adjustment | Original Activity ID Rebaseline | PRIOR MONTH EV COST | Activities with Steps | CR 13-007 | BOE Labor | BOE Expenses | CR 13-015 | Post Rebaseline | CR 14-001 | BOE Procurement | Obligated Prior to Rebaseline | CR 12-049 |
| --- | --- | --- | --- | --- | --- | --- | --- | --- | --- | --- | --- | --- | --- | --- | --- | --- | --- | --- | --- | --- | --- | --- | --- | --- | --- | --- | --- | --- | --- | --- | --- | --- | --- | --- | --- | --- | --- | --- | --- | --- | --- | --- | --- | --- | --- | --- | --- | --- | --- | --- | --- | --- | --- | --- | --- | --- | --- | --- |
|  | 6 | **1.5.6 INFRASTRUCTURE** |  |  | 2009-06-01 | 2014-10-01 |  |  |  |  |  |  |  |  |  |  |  |  |  |  |  |  |  |  |  |  |  |  |  |  |  |  |  |  |  |  |  |  |  |  |  |  |  |  |  |  |  |  |  |  |  |  |  |  |  |  |  |  |
|  | 1 | **1.5.6.1 ASSEMBLY** |  |  | 2010-04-26 | 2014-04-25 |  |  |  |  |  |  |  |  |  |  |  |  |  |  |  |  |  |  |  |  |  |  |  |  |  |  |  |  |  |  |  |  |  |  |  |  |  |  |  |  |  |  |  |  |  |  |  |  |  |  |  |  |
| 1561065 |  | Receive Modules 1-4 (Assy) |  | 21d | 2010-04-26 A | 2010-05-24 A | 15221215, 15221235, 15221205, 15221225 | 100% |  |  |  |  |  | MECH TECH [26.67 h]; PROCUREMENT<$50K 60; MECH ENG [5.33 h]; PLABOR | 6,079.18 | 1,464.27 | 0 | 2417.32894 | 241732.894 | 100 | 0 | 6079.171115 | CHUDAKOV | 1 | 1 | D | 07-024 | H | EUGENE C | 09-043 | 11-006 | 11-026 | 12-021F | 12-054F |  |  |  |  |  |  |  |  |  |  |  |  |  |  |  |  |  |  |  |  |  |  |  |  |
| 1561070 |  | Receive Modules 5-8 (Assy) |  | 5d | 2010-07-05 A | 2010-07-12 A | 15221245, 15221265, 15221275, 15221255 | 100% | 2010-07-06 | 2010-07-12 |  |  |  | PLABOR; MECH TECH [26.67 h]; PROCUREMENT<$50K 60; MECH ENG [5.33 h] | 6,079.18 | 1,464.27 | 0 | 2417.32894 | 241732.894 | 100 | 0 | 6079.171115 | CHUDAKOV | 1 | 1 | D | 07-024 | H | EUGENE C | 09-043 | 11-006 | 11-026 | 12-021F | 12-054F |  |  |  |  |  |  |  |  |  |  |  |  |  |  |  |  |  |  |  |  |  |  |  |  |
| 1561075 |  | Receive Modules 9-12 (Assy) |  | 3d | 2010-08-13 A | 2010-08-17 A | 195221045, 195221035, 195221055, 195221065 | 100% |  |  |  |  |  | MECH TECH [26.67 h]; PROCUREMENT<$50K 60; MECH ENG [5.33 h]; PLABOR | 6,079.18 | 1,464.27 | 0 | 2417.32894 | 241732.894 | 100 | 0 | 6079.171115 | CHUDAKOV | 1 | 1 | D | 07-024 | H | EUGENE C | 09-043 | 11-006 | 11-026 | 12-021F | 12-054F |  |  |  |  |  |  |  |  |  |  |  |  |  |  |  |  |  |  |  |  |  |  |  |  |
| 1561080 |  | Receive Modules 13-16 (Assy) FY10 |  | 13d | 2010-09-01 A | 2010-09-20 A | 195221075, 195221095, 195221085, 195221105 | 100% |  |  |  |  |  | MECH TECH [21.34 h]; MECH ENG [4.26 h]; PLABOR | 2,929.31 | 1,171.25 |  |  |  |  | 0 | 2929.3126 | CHUDAKOV | 1 | 1 | D | 07-024 | H | EUGENE C | 09-043 | 11-006 | 11-026 | 12-021F | 12-054F | 11-001 |  |  |  |  |  |  |  |  |  |  |  |  |  |  |  |  |  |  |  |  |  |  |  |
| 1561080a |  | Receive Modules 13-16 (Assy) FY11 |  | 13d | 2010-09-01 A | 2010-09-20 A | 1561080 | 100% |  |  |  |  |  | MECH TECH [5.33 h]; MECH ENG [1.07 h]; PLABOR | 746.47 | 292.93 |  |  |  |  | 0 | 755.8096 | CHUDAKOV | 1 | 1 | D | 07-024 | H | EUGENE C | 09-043 | 11-006 | 11-026 | 12-021F | 12-054F | 11-001 |  |  |  |  |  |  |  |  |  |  |  |  |  |  |  |  |  |  |  |  |  |  |  |
| 1561080b |  | Receive Modules 13-16 (Assy) Procurement |  | 13d | 2010-09-01 A | 2010-09-20 A | 195221105, 195221095, 195221075, 195221085 | 100% |  |  |  |  |  | PROCUREMENT<$50K 60 NO ESCALATION FY11 | 2,417.33 |  | 0 | 2417.32894 | 241732.894 | 100 | 0 | 2417.32894 | CHUDAKOV | 1 | 1 | D | 07-024 | H | EUGENE C | 09-043 | 11-006 | 11-026 | 12-021F | 12-054F | 11-001 |  |  |  |  |  |  |  |  |  |  |  |  |  |  |  |  |  |  |  |  |  |  |  |
| 1561085 |  | Receive Modules 17-20 (Assy) |  | 9d | 2010-11-15 A | 2010-11-29 A | 195221125, 195221145, 195221135, 195221115 | 100% |  |  |  |  |  | MECH ENG [5.33 h]; PLABOR; PROCUREMENT<$50K 60; MECH TECH [26.67 h] | 6,273.05 | 1,510.93 | 0 | 2494.44 | 249444 | 100 | 0 | 6273.053325 | CHUDAKOV | 1 | 1 | D | 07-024 | H | EUGENE C | 09-043 | 11-006 | 11-026 | 12-021F | 12-054F |  |  |  |  |  |  |  |  |  |  |  |  |  |  |  |  |  |  |  |  |  |  |  |  |
| 1561090 |  | Receive Modules 21-24 (Assy) |  | 24d | 2011-01-17 A | 2011-02-18 A | 195221165, 195221155, 195221185, 195221175 | 100% | 2011-01-18 | 2011-02-18 |  |  |  | MECH ENG [5.33 h]; MECH TECH [26.67 h]; PLABOR; PROCUREMENT<$50K 60 | 6,273.05 | 1,510.93 | 0 | 2494.44 | 249444 | 100 | 0 | 6273.053325 | CHUDAKOV | 1 | 1 | D | 07-024 | H | EUGENE C | 09-043 | 11-006 | 11-026 | 12-021F | 12-054F |  |  |  |  |  |  |  |  |  |  |  |  |  |  |  |  |  |  |  |  |  |  |  |  |
| 1561095 |  | Receive Modules 25-28 (Assy) |  | 15d | 2011-04-10 A | 2011-04-29 A | 195221205, 195221225, 195221215, 195221195 | 100% | 2011-04-11 | 2011-04-29 |  |  |  | MECH ENG [5.33 h]; MECH TECH [26.67 h]; PLABOR; PROCUREMENT<$50K 60 | 6,273.05 | 1,510.93 | 0 | 2494.44 | 249444 | 100 | 0 | 6273.053325 | CHUDAKOV | 1 | 1 | D | 07-024 | H | EUGENE C | 09-043 | 11-006 | 11-026 | 12-021F | 12-054F |  |  |  |  |  |  |  |  |  |  |  |  |  |  |  |  |  |  |  |  |  |  |  |  |
| 1561100 |  | Receive Modules 29-32 (Assy) |  | 11d | 2011-05-01 A | 2011-05-16 A | 195221245, 195221265, 195221235, 195221255 | 100% | 2011-05-02 | 2011-05-16 |  |  |  | PROCUREMENT<$50K 60; MECH ENG [5.33 h]; MECH TECH [26.67 h]; PLABOR | 6,273.05 | 1,510.93 | 0 | 2494.44 | 249444 | 100 | 0 | 6273.053325 | CHUDAKOV | 1 | 1 | D | 07-024 | H | EUGENE C | 09-043 | 11-006 | 11-026 | 12-021F | 12-054F |  | 1 |  |  |  |  |  |  |  |  |  |  |  |  |  |  |  |  |  |  |  |  |  |  |
| 1561101 |  | Receive Modules 33-36 (Assy) |  | 22d | 2011-06-01 A | 2011-06-30 A | 195221290, 195221300, 195221275, 195221310 | 100% |  |  |  |  |  | MECH TECH [26.67 h]; PLABOR; PROCUREMENT<$50K 60; MECH ENG [5.33 h] | 6,424.96 | 1,510.93 | 0 | 2574.01 | 257401 | 100 | 0 | 6473.069991 | CHUDAKOV | 1 | 1 | D | 07-024 | H | EUGENE C | 09-043 | 11-006 | 11-026 | 12-021F | 12-054F |  | 1 |  |  |  |  |  |  |  |  |  |  |  |  |  |  |  |  |  |  |  |  |  |  |
| 1561102 |  | Receive Modules 37-40 (Assy) |  | 23d | 2011-08-01 A | 2011-08-31 A | 195221330, 195221350, 195221320, 195221340 | 100% |  |  |  |  |  | MECH ENG [5.33 h]; MECH TECH [26.67 h]; PLABOR; PROCUREMENT<$50K 60 | 6,424.96 | 1,510.93 | 0 | 2574.01 | 257401 | 100 | 0 | 6473.069991 | CHUDAKOV | 1 | 1 | D | 07-024 | H | EUGENE C | 09-043 | 11-006 | 11-026 | 12-021F | 12-054F |  | 1 |  |  |  |  |  |  |  |  |  |  |  |  |  |  |  |  |  |  |  |  |  |  |
| 1561103 |  | Receive Modules 41-44 (Assy) |  | 5d | 2011-10-01 A | 2011-10-07 A | 195221380, 195221370, 195221390, 195221360 | 100% | 2011-10-03 | 2011-10-07 |  |  |  | MECH TECH [26.67 h]; PLABOR; PROCUREMENT<$50K 60; MECH ENG [5.33 h] | 6,473.07 | 1,559.04 | 0 | 2574.01 | 257401 | 100 | 0 | 6473.069991 | CHUDAKOV | 1 | 1 | D | 07-024 | H | EUGENE C | 09-043 | 11-006 | 11-026 | 12-021F | 12-054F |  | 1 |  |  |  |  |  |  |  |  |  |  |  |  |  |  |  |  |  |  |  |  |  |  |
| 1561104 |  | Receive Modules 45-48 (Assy) |  | 6d | 2011-12-12 A | 2011-12-19 A | 195221410, 195221400, 195221420, 195221430 | 100% |  |  |  |  |  | MECH ENG [5.33 h]; MECH TECH [26.67 h]; PROCUREMENT<$50K 60; PLABOR | 6,473.07 | 1,559.04 | 0 | 2574.01 | 257401 | 100 | 0 | 6473.069991 | CHUDAKOV | 1 | 1 | D | 07-024 | H | EUGENE C | 09-043 | 11-006 | 11-026 | 12-021F | 12-054F |  | 1 |  |  |  |  |  |  |  |  |  |  |  |  |  |  |  |  |  |  |  |  |  |  |
| 1561105 |  | BCAL lightguide gluing, preparation for installation (Assy) FY12 |  | 62d | 2013-01-07 A | 2013-07-15 A | 1561070, 1561080a, 1561101, 15221165, 15221020, 15221160b, 1561103, 1561100, 195221435M, 15221009, 1561065, 1561090, 15221030, 15221160ab, 1561095, 1561085, 15221160aba, 1561104, 1561080b, 1561102, 1561075 | 100% | 2013-02-01 | 2013-04-30 |  |  |  | MECH DES [29.47 h]; MECH ENG [29.47 h]; MECH TECH [478.97 h] | 25,562.96 | 25,562.96 |  |  |  |  | 4458.857958 | 24771.4331 | CHUDAKOV | 1 | 1 | D | 07-024 | U | EUGENE C | 09-043 | 11-006 | 11-026 | 12-021 | 12-054F |  | 1 | 12-053 |  |  |  |  |  |  |  |  |  |  |  |  |  |  |  |  |  |  |  |  |  |
| 1561105a |  | BCAL lightguide gluing, preparation for installation (Assy) FY13 |  | 62d | 2013-01-07 A | 2013-07-15 A | 1561105 FS-62d | 100% | 2013-02-01 | 2013-04-30 |  |  |  | MECH ENG [45.27 h]; MECH TECH [735.55 h]; MECH DES [45.27 h] | 39,258.43 | 39,258.43 |  |  |  |  | 7066.517742 | 39258.4319 | CHUDAKOV | 1 | 1 | D | 07-024 | U | EUGENE C | 09-043 | 11-006 | 11-026 | 12-021 | 12-054F |  | 1 | 12-053 |  |  |  |  |  |  |  |  |  |  |  |  |  |  |  |  |  |  |  |  |  |
| 1561155 |  | Assemble BCal readout wedges(Assy) FY12 |  | 40d | 2013-02-01 A | 2013-06-17 A | 1562242, 1562240b, 15221156n FS-40d, 1562240a | 100% | 2013-03-01 | 2013-04-25 |  |  |  | MECH ENG [53.78 h]; MECH TECH [147.9 h] | 10,674.21 | 10,674.21 |  |  |  |  | 0 | 10343.7296 | CHUDAKOV | 1 | 1 | D |  | U | EUGENE C | 09-043 | 11-006 | 11-026 | 12-021 | 12-054F |  |  | 12-053 | 09-014 | 09-027 | 09-027 |  |  |  |  |  |  |  |  |  |  |  |  |  |  |  |  |  |  |
| 1561155a |  | Assemble BCal readout wedges(Assy) FY13 |  | 79d | 2013-02-01 A | 2013-06-17 A | 1561155 FS-100d, 1561105a FS-85d | 100% | 2013-04-26 | 2013-08-16 |  |  |  | MECH ENG [106.22 h]; MECH TECH [292.1 h] | 21,081.79 | 21,081.79 |  |  |  |  | 0 | 21081.7852 | CHUDAKOV | 1 | 1 | D |  | U | EUGENE C | 09-043 | 11-006 | 11-026 | 12-021 | 12-054F |  |  | 12-053 | 09-014 | 09-027 | 09-027 | 11-054 |  |  |  |  |  |  |  |  |  |  |  |  |  |  |  |  |  |
| 1561155b |  | Assemble BCal readout wedges(Assy) Procurement |  | 119d | 2013-02-01 A | 2013-06-17 A | 1562242, 1562240b, 1562240a, 1561105a FS-85d, 15221156n FS-40d, 9-130M | 100% | 2013-03-18 | 2013-09-03 |  |  |  | PROCUREMENT<$50K 60 NO ESCALATION FY13 | 25,000 |  | 0 | 25000 | 2500000 | 100 | 0 | 25000 | CHUDAKOV | 1 | 1 | D |  | D | EUGENE C | 09-043 | 11-006 | 11-026 | 12-021 |  |  |  | 12-053 | 09-014 | 09-027 | 09-027 | 11-054 |  |  |  |  |  |  |  |  |  |  |  |  |  |  |  |  |  |
| 1561040M |  | Delivery Complete for CDC (Assy) | milestone | 0d | 2013-08-30 A | 2013-08-30 A | 15212013E, 15212200 | 100% | 2013-10-02 | 2013-10-02 |  |  |  |  |  |  |  |  |  |  |  | 0 | CHUDAKOV | 1 | 1 | D |  | M | EUGENE C |  | 11-006 | 11-026 |  | 12-054F |  |  |  |  |  |  |  | 6 |  |  |  |  |  |  |  |  |  |  |  |  |  |  |  |  |
| 1561050M |  | Complete FDC (Assy) | milestone | 0d | 2013-08-30 A | 2013-08-30 A | 15211230 | 100% | 2013-09-03 | 2013-09-03 |  |  |  |  |  |  |  |  |  |  |  | 0 | CHUDAKOV | 1 | 1 | D |  | M | EUGENE C |  | 11-006 | 11-026 |  | 12-054 |  |  |  | 09-014 |  |  |  | 6 | 10-042 |  |  |  |  |  |  |  |  |  |  |  |  |  |  |  |
| 1561110 |  | Receive CDC (Assy) |  | 10d | 2013-08-30 A | 2013-08-30 A | 195212260, 1561040M | 100% | 2013-10-02 | 2013-10-15 |  |  |  | PROCUREMENT<$50K 60; ELEC ENG [200 h]; ELEC TECH [400 h] | 36,478.12 | 32,778 | 0 | 2656.12 | 265612 | 100 | 35434.12 | 35434.12 | CHUDAKOV | 1 | 1 | D | 07-024 | H | EUGENE C |  | 11-006 | 11-026 |  | 12-054F |  |  |  |  |  |  |  |  |  | 1561110 |  |  |  |  |  |  |  |  |  |  |  |  |  |  |
| 1561115 |  | Mounting CDC (Assy) |  | 20d | 2013-08-30 A | 2013-08-30 A | 1561110 | 100% | 2013-10-16 | 2013-11-12 |  |  |  | MECH TECH [160 h]; PROCUREMENT<$50K 60; MECH ENG [80 h] | 43,728.02 | 13,126.4 | 0 | 30183.22 | 3018322 | 100 | 43309.62 | 43309.62 | CHUDAKOV | 1 | 1 | D | 07-024 | H | EUGENE C |  | 11-006 | 11-026 |  | 12-054F |  |  |  |  |  |  |  |  |  | 1561115 | 09-012 |  |  |  |  |  |  |  |  |  |  |  |  |  |
| 1561120 |  | Alignment CDC (Assy) |  | 20d | 2013-08-30 A | 2013-08-30 A | 1561115, 12361005 | 100% | 2013-11-13 | 2013-12-12 |  |  |  | MECH TECH [400 h]; MECH ENG [160 h] | 30,875.2 | 29,921.6 |  |  |  |  | 29921.6 | 29921.6 | CHUDAKOV | 1 | 1 | D | 07-024 | H | EUGENE C |  | 11-006 | 11-026 |  | 12-054F |  |  |  |  |  |  |  |  |  | 1561120 |  |  |  |  |  |  |  |  |  |  |  |  |  |  |
| 1561125 |  | Operational Checks CDC (outside Solenoid) (Assy) |  | 20d | 2013-08-30 A | 2013-08-30 A | 1561120 | 100% | 2013-12-13 | 2014-01-17 |  |  |  | ELEC ENG [200 h]; ELEC TECH [600 h] | 43,220 | 41,886 |  |  |  |  | 41886 | 41886 | CHUDAKOV | 1 | 1 | D | 07-024 | H | EUGENE C |  | 11-006 | 11-026 |  | 12-054F |  |  |  |  |  |  |  |  |  |  |  |  |  |  |  |  |  |  |  |  |  |  |  |  |
| 1561140 |  | Receive FDC (Assy) |  | 4d | 2013-08-30 A | 2013-08-30 A | 15211185, 15211191 FS-200d, 15211012E, 15211220 FS-55d, 1561050M | 100% | 2013-11-12 | 2013-11-15 |  |  |  | MECH ENG [80 h]; MECH TECH [320 h] | 21,116 | 20,464 |  |  |  |  | 20464 | 20464 | CHUDAKOV | 1 | 1 | D | 07-024 | H | EUGENE C |  | 11-006 | 11-026 |  | 12-054 |  |  |  | 09-014 |  |  |  |  | 10-042 |  |  |  |  |  |  |  |  |  |  |  |  |  |  |  |
| 1561145 |  | Rail Mounting for FDC (Assy) |  | 10d | 2013-08-30 A | 2013-08-30 A | 1561140 | 100% | 2013-11-18 | 2013-12-03 |  |  |  | MECH ENG [283.2 h]; ELEC TECH [144 h]; PROCUREMENT<$50K 60 | 60,523.14 | 27,050.11 | 0 | 32610.04 | 3261004 | 100 | 59660.152 | 59660.152 | CHUDAKOV | 1 | 1 | D | 07-024 | H | EUGENE C |  | 11-006 | 11-026 |  | 12-054 |  |  |  | 09-014 |  |  |  |  | 10-042 |  |  |  |  |  |  |  |  |  |  |  |  |  |  |  |
| 1561170 |  | Re-Baseline Actuals Adjustment |  | 1d | 2013-08-30 A | 2013-08-30 A |  | 100% | 2013-09-03 | 2013-09-03 |  |  |  | PROCUREMENT>$50K 69 NO ESCALATION | -199,966.79 |  |  |  |  | 100 |  |  |  |  |  |  |  |  |  |  |  |  |  |  |  |  |  |  |  |  |  |  |  |  |  | ADJ |  |  |  |  |  |  |  |  |  |  |  |  |
| 2561145 |  | Rail Mounting for FDC (Assy) FY13 |  | 32d | 2013-09-03 A | 2013-10-21 A | 2562225 FS-18d | 100% | 2013-10-03 | 2013-11-15 |  |  | 8/5 M-F w/JLAB Holidays ReBaseline | MECH ENG [6.75 h]; ELEC TECH; MECH DES [4.5 h]; MECH TECH [105.75 h]; SUPPLIES & MATERIALS | 6,076.46 | 5,683.3 |  |  |  |  |  | 1356.8436 | CHUDAKOV | 1 | 1 | D | 07-024 | S | EUGENE C |  | 11-006 | 11-026 |  | 12-054 |  |  |  | 09-014 |  |  |  |  | 10-042 |  |  |  | 2561145 | 4542.4764 | ST | 13-007 | PE | EJ | 13-015 | PR |  |  |  |  |
| 2561145a |  | Rail Mounting for FDC (Assy) FY14 |  | 14d | 2013-09-03 A | 2013-10-21 A | 2561145 FS-20d | 100% | 2013-10-01 | 2013-10-18 |  |  | 8/5 M-F w/JLAB Holidays ReBaseline | MECH ENG [5.25 h]; ELEC TECH; MECH DES [3.5 h]; MECH TECH [82.25 h]; SUPPLIES & MATERIALS | 4,734.51 | 4,415.29 |  |  |  |  |  | 1088.936725 | CHUDAKOV | 1 | 1 | D | 07-024 | S | EUGENE C |  | 11-006 | 11-026 |  | 12-054 |  |  |  | 09-014 |  |  |  |  | 10-042 |  |  |  | 2561145 | 3645.570775 | ST | 13-007 | PE | EJ | 13-015 | PR | 14-001 |  |  |  |
| 2561050M |  | Complete FDC (Assy) | milestone | 0d | 2013-09-30 A | 2013-09-30 A | 25211208 | 100% | 2013-10-01 | 2013-10-01 |  |  | 8/5 M-F w/JLAB Holidays ReBaseline |  |  |  |  |  |  |  |  | 0 | CHUDAKOV | 1 | 1 | D |  | M | EUGENE C |  | 11-006 | 11-026 |  | 12-054 |  |  |  | 09-014 |  |  |  | 6 | 10-042 |  |  |  | 2561050M |  |  | 13-007 |  |  | 13-015 | PR |  |  |  |  |
| 2561110 |  | Receive CDC for Storage (Assy) |  | 25d | 2013-10-01 A | 2013-10-21 A | 295212260 FS-6d, 2561040M FS-6d | 100% | 2013-11-26 | 2014-01-13 |  |  | 8/5 M-F w/JLAB Holidays ReBaseline | MECH TECH [80 h]; MECH ENG [40 h]; ELEC TECH [40 h]; PROCUREMENT<$50K 60; SCIENTIST [40 h] | 14,400.05 | 11,659.2 | 0 | 2740.85 | 274085 | 100 |  | 14400.05 | CHUDAKOV | 1 | 1 | D | 07-024 | S | EUGENE C |  | 11-006 | 11-026 |  | 12-054F |  |  |  |  |  |  |  |  |  |  |  |  | 2561110 |  | ST | 13-007 | EJ |  | 13-015 | PR | 14-001 | EJ | OB-2 |  |
| 2561140 |  | Receive FDC (Assy) |  | 5d | 2013-10-01 A | 2013-10-07 A | 25211172 FS-40d, 25211220 FS-55d, 2561050M, 25211172a FS-40d | 100% | 2013-11-01 | 2013-11-07 |  |  | 8/5 M-F w/JLAB Holidays ReBaseline | MECH TECH [40 h]; MECH ENG [20 h] | 3,386.2 | 3,386.2 |  |  |  |  |  | 3386.2 | CHUDAKOV | 1 | 1 | D | 07-024 | H | EUGENE C |  | 11-006 | 11-026 |  | 12-054 |  |  |  | 09-014 |  |  |  |  | 10-042 |  |  |  | 2561140 |  |  | 13-007 | PE |  | 13-015 | PR | 14-001 |  |  |  |
| 2561040M |  | Delivery Complete for CDC (Assy) | milestone | 0d | 2013-11-01 | 2013-11-01 | 295212260 |  |  |  | 88d | 6d | 8/5 M-F w/JLAB Holidays ReBaseline |  |  |  |  |  |  |  |  | 0 | CHUDAKOV | 1 | 1 | D |  | M | EUGENE C |  | 11-006 | 11-026 |  | 12-054F |  |  |  |  |  |  |  | 6 |  |  |  |  | 2561040M |  |  | 13-007 |  |  | 13-015 | PR |  |  |  |  |
| 2561060M |  | Delivery Complete for TOF (Assy) | milestone | 0d | 2013-12-03 | 2013-12-03 | 25231010a FS-200d, 25231145 FS-15d, 25231010 FS-200d, 25231085, 25231090 |  |  |  | 68d | 0d | 8/5 M-F w/JLAB Holidays ReBaseline |  |  |  |  |  |  |  |  | 0 | CHUDAKOV | 1 | 1 | D |  | M | EUGENE C |  | 11-006 | 11-026 | 12-021 | 12-054 |  |  |  |  |  |  |  | 6 |  |  |  |  | 2561060M |  |  | 13-007F |  |  | 13-015 | PR |  |  |  | 12-049 |
| 2561160 |  | Receive TOF Detector Units (Assy) |  | 10d | 2013-12-03 | 2013-12-16 | 2561060M |  |  |  | 68d | 5d | 8/5 M-F w/JLAB Holidays ReBaseline | MECH TECH [40 h]; MECH ENG [20 h] | 3,386.2 |  |  |  |  |  |  | 0 | CHUDAKOV | 1 | 1 | D | 07-024 | H | EUGENE C |  | 11-006 | 11-026 | 12-021 | 12-054 |  |  |  |  |  |  |  |  |  |  |  |  | 2561160 |  |  | 13-007F | PE |  | 13-015 | PR | 14-001 |  |  | 12-049 |
| 2561165 |  | Mount TOF Counters onto Detector Frame (Assy) |  | 60d | 2014-02-03 | 2014-04-25 | 25231030, 25231045, 2561160 FS+20d |  |  |  | 64d | 0d | 8/5 M-F w/JLAB Holidays ReBaseline | MECH TECH [400 h]; PROCUREMENT<$50K 60; MECH ENG [40 h] | 33,127.38 |  | 11212.58 | 0 | 0 | 100 |  | 0 | CHUDAKOV | 1 | 1 | D | 07-024 | S | EUGENE C |  | 11-006 | 11-026 | 12-021 | 12-054 |  |  |  |  |  |  |  |  |  |  |  |  | 2561165 |  | ST | 13-007F | EJ |  | 13-015 | PR | 14-001 | PE |  | 12-049 |

Notes:
- 2561145: Steps: Remove BCAL platform (done); install FDC cable tray supports (done); install upper portion of platform (done); install cable trays for FDC (done); Install rails for FDC (done); Survey and align (initial) (done)
- 2561145a: Steps: Remove BCAL platform (done); install FDC cable tray supports (done); install upper portion of platform (done); install cable trays for FDC (done); Install rails for FDC (done); Survey and align (initial) (done)
- 2561110: Steps: Receive CDC for Storage (Assy) (done)
- 2561165: Steps: assemble frame bottom half; install 200 paddles; assemble top half of frames; install mag shields and adjust; test paddles

| ID | WBS | Activity | Type | Duration | Start | Finish | Predecessors | Complete | Planned start | Planned finish | Resources | Cost | Actual cost | LOE Divider | LOE Multiplier | Calculated Remaining Total Cost | MONTHLY EV COST | RESP - Responsibility | STRT%COMP for CM EVM | FNSH%COMP for CM EVM | HALL D Related Milestones | CR 07-024 | EVMS Reporting Codes | CAM RESPONSIBLE | CR 09-027 | CR 09-027 Repair | CR 11-026 | LOE % Pre Calc | LOE % | CR 10-061 | CR 11-004 | CR 11-006 | CR 11-036 | Advance Purchase Plan > 500K | CR 12-021 | 12 GeV 1st level Critical Path | CR 09-014 | CR 10-042 | CR 12-054 | Remaining Material Cost Based on % Compl | Claimed Material Cost Based on % Complet | Initial Claimed Material Calc | Claimed Material Divider | Activities with Steps | CR 12-055 | CR 09-046 | CR 12-001 | 12 GeV 2nd level Critical Path | Specification | CR 07-027 | MARCH!!! | CR 10-059 | Milestone Level | CR 09-043 | New H Claim | CR 11-044 | CR 08-016 | CR 10-009 |
| --- | --- | --- | --- | --- | --- | --- | --- | --- | --- | --- | --- | --- | --- | --- | --- | --- | --- | --- | --- | --- | --- | --- | --- | --- | --- | --- | --- | --- | --- | --- | --- | --- | --- | --- | --- | --- | --- | --- | --- | --- | --- | --- | --- | --- | --- | --- | --- | --- | --- | --- | --- | --- | --- | --- | --- | --- | --- | --- |
|  | 2 | **1.5.6.2 INSTALLATION** |  |  | 2009-06-01 | 2014-10-01 |  |  |  |  |  |  |  |  |  |  |  |  |  |  |  |  |  |  |  |  |  |  |  |  |  |  |  |  |  |  |  |  |  |  |  |  |  |  |  |  |  |  |  |  |  |  |  |  |  |  |  |  |
| 1562001LOE |  | FY09 Work Cordinator (Installtn) |  | 86d | 2009-06-01 A | 2009-09-30 A | 9-090M FS+162d | 100% |  |  | MECH ENG [320 h] | 20,419.2 | 20,419.2 | 100 | 100 | 0 | 20419.2 | CHUDAKOV | 1 | 1 | D | 07-024 | E | EUGENE C | 09-027 | 09-027 | 11-026 |  |  |  |  |  |  |  |  |  |  |  |  |  |  |  |  |  |  |  |  |  |  |  |  |  |  |  |  |  |  |  |
| 1562002LOE |  | FY10 Work Cordinator (Installtn) |  | 248d | 2009-10-01 A | 2010-09-30 A | 1562001LOE | 100% |  |  | MECH ENG [1760 h] | 115,896 | 115,896 | 100 | 100 | 0 | 115896 | CHUDAKOV | 1 | 1 | D | 07-024 | E | EUGENE C | 09-027 | 09-027 | 11-026 |  |  |  |  |  |  |  |  |  |  |  |  |  |  |  |  |  |  |  |  |  |  |  |  |  |  |  |  |  |  |  |
| 1562010E |  | FY10 Travel (Installtn) |  | 248d | 2009-10-01 A | 2010-09-30 A | 9-100M | 100% |  |  | TRAVEL | 1,318.54 |  | 100 | 100 | 0 | 1318.541182 | CHUDAKOV | 1 | 1 | D | 07-024 | E | EUGENE C |  |  | 11-026 |  |  |  |  |  |  |  |  |  |  |  |  |  |  |  |  |  |  |  |  |  |  |  |  |  |  |  |  |  |  |  |
| 1562003LOE |  | FY11 Work Cordinator (Installtn) |  | 248d | 2010-10-01 A | 2011-09-30 A | 1562002LOE | 100% |  |  | MECH ENG [1760 h] | 119,592 | 119,592 | 100 | 100 | 0 | 119592 | CHUDAKOV | 1 | 1 | D | 07-024 | E | EUGENE C | 09-027 | 09-027 | 11-026 | 8.46774193 | 91.53225806 |  |  |  |  |  |  |  |  |  |  |  |  |  |  |  |  |  |  |  |  |  |  |  |  |  |  |  |  |  |
| 1562011E |  | FY11 Travel (Installtn) |  | 248d | 2010-10-01 A | 2011-09-30 A | 1562010E | 100% |  |  | TRAVEL | 1,360.6 |  | 100 | 100 | 0 | 1360.6 | CHUDAKOV | 1 | 1 | D | 07-024 | E | EUGENE C |  |  | 11-026 | 8.46774193 | 91.53225806 |  |  |  |  |  |  |  |  |  |  |  |  |  |  |  |  |  |  |  |  |  |  |  |  |  |  |  |  |  |
| 1562149 |  | Installation Safety & Planning Platform #5 (Installtn) |  | 12d | 2010-12-01 A | 2010-12-16 A | 2-10M FS-135d | 100% |  |  | MECH TECH [400 h] | 17,228 | 17,228 |  |  | 0 | 16696 | CHUDAKOV | 1 | 1 | D | 07-024 | H | EUGENE C |  |  |  |  |  | 10-061 | 11-004 | 11-006 | 11-036 |  |  |  |  |  |  |  |  |  |  |  |  |  |  |  |  |  |  |  |  |  |  |  |  |  |
| 1562099d |  | Prepare procurement packages for col cave vacuum |  | 56d | 2011-01-05 A | 2011-03-25 A | 9-110M FS+60d | 100% |  |  | MECH ENG [80 h]; MECH DES [320 h] | 20,373.6 | 20,373.6 |  |  | 0 | 20373.6 | CHUDAKOV | 1 | 1 | D | 07-024 | H | EUGENE C |  |  | 11-026 |  |  |  |  | 11-006 |  | APP | 12-021F |  |  |  |  |  |  |  |  |  |  |  |  |  |  |  |  |  |  |  |  |  |  |  |
| 1562237 |  | Prepare procurement packages for upstream platform |  | 101d | 2011-01-05 A | 2011-05-27 A | 9-110M FS+60d | 100% |  |  | MECH DES [320 h]; MECH ENG [120 h] | 23,091.6 | 23,091.6 |  |  | 0 | 23091.6 | CHUDAKOV | 1 | 1 | D | 07-024 | H | EUGENE C | 09-027 | 09-027 | 11-026 |  |  |  | 11-004 | 11-006 |  | APP | 12-021F | 1 | 09-014 | 10-042 | 12-054F |  |  |  |  |  |  |  |  |  |  |  |  |  |  |  |  |  |  |  |
| 1562595 |  | Installation work space infrastructure (TW's Doublewide) Part A |  | 482d | 2011-01-24 A | 2012-12-31 A | 9-110M FS+81d | 100% |  |  | PROCUREMENT<$50K 60; PROCUREMENT>$50K 69 | 58,000 |  |  |  | 0 | 58000 | CHUDAKOV | 1 | 1 | D |  | S | EUGENE C |  |  | 11-026 |  |  |  |  | 11-006 |  |  |  | 1 |  |  |  | 0 | 58000 | 5800000 | 100 | ST | 12-055 |  |  |  |  |  |  |  |  |  |  |  |  |  |
| 1562600 |  | Installation Equipment infrastructure |  | 176d | 2011-01-24 A | 2011-09-30 A | 9-110M FS+81d | 100% |  |  | PROCUREMENT<$50K 60 | 25,000 |  | 100 | 100 | 0 | 25000 | CHUDAKOV | 1 | 1 | D |  | E | EUGENE C |  |  | 11-026 | 12.57485029 | 87.4251497 |  |  | 11-006 |  |  |  | 1 |  |  |  | 0 | 25000 | 2500000 | 100 |  |  |  |  |  |  |  |  |  |  |  |  |  |  |  |
| 1562101 |  | Procure hdwre for collimator cave utilities |  | 149d | 2011-02-01 A | 2011-08-31 A | 9-110M FS+60d | 100% |  |  | PROCUREMENT>$50K 69 | 20,000 |  |  |  | 0 | 20000 | CHUDAKOV | 1 | 1 | D | 07-024 | D | EUGENE C |  |  | 11-026 |  |  |  | 11-004 | 11-006 |  | APP | 12-021F |  | 09-014 |  |  | 0 | 20000 | 2000000 | 100 |  |  | 09-046 |  |  |  |  |  |  |  |  |  |  |  |  |
| 1562102 |  | Install collimator cave utilities(Installtn) |  | 262d | 2011-03-01 A | 2012-03-19 A | 9-110M FS+70d, 1562101 FS-95d | 100% |  |  | MECH TECH [760 h]; MECH DES [320 h]; MECH ENG [240 h] | 64,842.56 | 64,842.56 |  |  | 0 | 63978.8 | CHUDAKOV | 1 | 1 | D | 07-024 | S | EUGENE C |  |  | 11-026 |  |  |  | 11-004 | 11-006 |  | APP | 12-021F |  | 09-014 |  |  |  |  |  |  | ST |  | 09-046 |  |  |  |  |  |  |  |  |  |  |  |  |
| 1562105 |  | Fab Collimator Cave Stands (Installtn) |  | 44d | 2011-03-01 A | 2011-04-29 A | 9-110M FS+60d | 100% |  |  | PROCUREMENT>$50K 69 | 11,338.37 |  |  |  | 0 | 11338.37 | CHUDAKOV | 1 | 1 | D | 07-024 | D | EUGENE C |  |  | 11-026 |  |  |  | 11-004 |  |  | APP | 12-021F |  | 09-014 |  |  | 0 | 11338.37 | 1133837 | 100 |  |  | 09-046 |  |  |  |  |  |  |  |  |  |  |  |  |
| 1562132 |  | Install Collimator cave stands (Installtn) |  | 37d | 2011-04-01 A | 2011-05-23 A | 1562105 FS-64d | 100% |  |  | MECH TECH [280 h]; MECH DES [240 h]; MECH ENG [40 h] | 25,980.8 | 25,980.8 |  |  | 0 | 25980.8 | CHUDAKOV | 1 | 1 | D | 07-024 | H | EUGENE C |  |  | 11-026 |  |  |  | 11-004 | 11-006 |  | APP | 12-021F |  | 09-014 |  |  |  |  |  |  |  |  |  |  |  |  |  |  |  |  |  |  |  |  |  |
| 1562100 |  | Fab Collimator Cave Vac (Installtn) |  | 370d | 2011-05-01 A | 2012-10-22 A | 9-110M FS+60d, 1562099d FS-30d | 100% | 2011-05-02 | 2012-10-22 | PROCUREMENT>$50K 69 | 11,338.37 |  |  |  | 0 | 11338.37 | CHUDAKOV | 1 | 1 | D | 07-024 | D | EUGENE C |  |  | 11-026 |  |  |  | 11-004 | 11-006 |  | APP | 12-021F |  | 09-014 |  |  | 0 | 11338.37 | 1133837 | 100 |  |  | 09-046 |  |  |  |  |  |  |  |  |  |  |  |  |
| 1562394 |  | Prepare procurement packages for downstream platform |  | 213d | 2011-05-09 A | 2012-03-19 A | 9-120M FS-150d | 100% |  |  | MECH ENG [160 h]; MECH TECH [480 h]; MECH DES [160 h]; SCIENTIST [80 h] | 45,227.55 | 45,227.55 |  |  | 0 | 45906.4 | CHUDAKOV | 1 | 1 | D | 07-024 | S | EUGENE C |  |  | 11-026 |  |  |  |  | 11-006 |  |  |  |  | 09-014 | 10-042 | 12-054F |  |  |  |  | ST |  |  |  |  |  |  |  |  |  |  |  |  |  |  |
| 1562240 |  | Fab Upstream Platform CDC #1 (Installtn) Expenses FY11 |  | 98d | 2011-08-01 A | 2011-12-19 A | 1562425 FS-160d, 1562237, 2-10M | 100% |  |  | PLABOR | 9,702.66 |  |  |  | 0 | 9702.66 | CHUDAKOV | 1 | 1 | D | 07-024 | D | EUGENE C | 09-027 | 09-027 | 11-026 |  |  |  | 11-004 | 11-006 |  | APP | 12-021F | 1 | 09-014 | 10-042 | 12-054F |  |  |  |  |  |  |  | 12-001 |  |  |  |  |  |  |  |  |  |  |  |
| 1562240a |  | Fab Upstream Platform CDC #1 (Installtn) Expenses FY12 |  | 98d | 2011-08-01 A | 2011-12-19 A | 1562240 FS-40d | 100% |  |  | PLABOR | 4,027.89 |  |  |  | 0 | 4027.89 | CHUDAKOV | 1 | 1 | D | 07-024 | D | EUGENE C | 09-027 | 09-027 | 11-026 |  |  |  | 11-004 | 11-006 |  | APP | 12-021F | 1 | 09-014 | 10-042 | 12-054F |  |  |  |  |  |  |  | 12-001 |  |  |  |  |  |  |  |  |  |  |  |
| 1562240b |  | Fab Upstream Platform CDC #1 (Installtn) Procurement |  | 98d | 2011-08-01 A | 2011-12-19 A | 1562425 FS-160d, 1562237, 2-10M | 100% |  |  | PROCUREMENT>$50K 69 NO ESCALATION FY12 | 73,699.37 |  |  |  | 0 | 73699.37 | CHUDAKOV | 1 | 1 | D | 07-024 | D | EUGENE C | 09-027 | 09-027 | 11-026 |  |  |  | 11-004 | 11-006 |  | APP | 12-021F | 1 | 09-014 | 10-042 | 12-054F | 0 | 73699.37 | 7369937 | 100 |  |  |  | 12-001 |  |  |  |  |  |  |  |  |  |  |  |
| 1562423 |  | Prepare solenoid and temporary platform Procurements/Fabrication Packages (Installtn) |  | 200d | 2011-08-01 A | 2012-05-21 A | 9-110M FS+141d | 100% |  |  | MECH ENG [360 h]; MECH DES [800 h] | 63,345.1 | 63,345.1 |  |  | 0 | 61806 | CHUDAKOV | 1 | 1 | D | 07-024 | S | EUGENE C | 09-027 | 09-027 | 11-026 |  |  |  | 11-004 | 11-006 |  |  | 12-021F |  | 09-014 |  | 12-054F |  |  |  |  | ST |  |  |  | 2 |  |  |  |  |  |  |  |  |  |  |
| 1562004LOE |  | FY12 Work Cordinator (Installtn) |  | 247d | 2011-10-03 A | 2012-09-28 A | 1562003LOE | 100% |  |  | MECH ENG [1760 h] | 123,411.2 | 123,411.2 | 100 | 100 | 0 | 123411.2 | CHUDAKOV | 1 | 1 | D | 07-024 | E | EUGENE C | 09-027 | 09-027 | 11-026 | 7.69230769 | 92.3076923 |  |  |  |  |  |  |  |  |  |  |  |  |  |  |  |  |  |  |  |  |  |  |  |  |  |  |  |  |  |
| 1562012E |  | FY12 Travel (Installtn) |  | 247d | 2011-10-03 A | 2012-09-28 A | 1562011E | 100% |  |  | TRAVEL | 1,404 |  | 100 | 100 | 0 | 1404 | CHUDAKOV | 1 | 1 | D | 07-024 | E | EUGENE C |  |  | 11-026 | 7.69230769 | 92.3076923 |  |  |  |  |  |  |  |  |  |  |  |  |  |  |  |  |  |  |  |  |  |  |  |  |  |  |  |  |  |
| 1562100b |  | Install col cave vacuum FY11 |  | 68d | 2011-10-10 A | 2012-01-24 A | 1562099d, 1562100 FS-30d | 100% |  |  | MECH ENG [25.41 h]; MECH DES [25.41 h]; MECH TECH [304.94 h] | 16,557.28 | 16,557.28 |  |  | 0 | 16046.5141 | CHUDAKOV | 1 | 1 | D | 07-024 | H | EUGENE C |  |  | 11-026 |  |  |  |  | 11-006 |  | APP | 12-021F |  |  |  |  |  |  |  |  |  |  |  | 12-001 |  |  |  |  |  |  |  |  |  |  |  |
| 1562100ba |  | Install col cave vacuum FY12 |  | 71d | 2011-10-10 A | 2012-01-27 A | 1562100b FS-90d | 100% |  |  | MECH ENG [14.59 h]; MECH DES [14.59 h]; MECH TECH [175.06 h] | 9,505.52 | 9,505.52 |  |  | 0 | 9505.5175 | CHUDAKOV | 1 | 1 | D | 07-024 | H | EUGENE C |  |  | 11-026 |  |  |  |  | 11-006 |  | APP | 12-021F |  |  |  |  |  |  |  |  |  |  |  | 12-001 |  | 1562100ba |  |  |  |  |  |  |  |  |  |
| 1562242 |  | Oversee installation for upstream platform |  | 29d | 2011-11-07 A | 2011-12-19 A | 1562240a FS-20d, 1562240b FS-20d | 100% |  |  | MECH TECH [160 h]; MECH ENG [80 h]; MECH DES [40 h] | 14,646.8 | 14,646.8 |  |  | 0 | 14646.8 | CHUDAKOV | 1 | 1 | D | 07-024 | H | EUGENE C | 09-027 | 09-027 | 11-026 |  |  |  | 11-004 | 11-006 |  | APP | 12-021F | 1 | 09-014 | 10-042 | 12-054F |  |  |  |  |  |  |  |  |  |  |  |  |  |  |  |  |  |  |  |
| 1562130 |  | Install Collimator Mag Sweep # 1 (Installtn) |  | 9d | 2011-11-14 A | 2011-11-28 A | 1562100ba, 1562100 FS-30d, 1562105, 1553100, 1562102 | 100% |  |  | MECH TECH [240 h]; MECH ENG [40 h]; PROCUREMENT<$50K 60 | 28,680.48 | 13,470.4 |  |  | 0 | 28680.48 | CHUDAKOV | 1 | 1 | D | 07-024 | H | EUGENE C |  |  | 11-026 |  |  |  | 11-004 | 11-006 |  | APP | 12-021F |  | 09-014 |  |  | 0 | 15210.08 | 1521008 | 100 |  |  |  |  |  |  |  |  |  |  |  |  |  |  |  |
| 1562110 |  | Proc Collimator #2 and Obtain SEG Blocks (Installtn) |  | 67d | 2011-12-05 A | 2012-03-16 A | 9-120M FS+60d | 100% |  |  | MECH TECH [40 h]; PROCUREMENT>$50K 69; MECH ENG [8 h] | 24,568.67 | 2,338.56 |  |  | 0 | 24568.67 | CHUDAKOV | 1 | 1 | D | 07-024 | H | EUGENE C |  |  | 11-026 |  |  |  |  |  |  | APP | 12-021F |  | 09-014 |  |  | 0 | 22230.11 | 2223011 | 100 |  |  |  |  |  |  |  |  |  |  |  |  |  |  |  |
| 1562055 |  | Install LCW Connections (Installtn) |  | 278d | 2011-12-12 A | 2013-02-11 A | 1562050 FS-210d, 1562430 FS-200d | 100% | 2011-12-12 | 2013-01-30 | MECH TECH [200 h]; MECH ENG [40 h]; PROCUREMENT<$50K 60 | 20,998.97 | 11,806.45 |  |  | 0 | 20892.8 | CHUDAKOV | 1 | 1 | D | 07-024 | H | EUGENE C |  |  | 11-026 |  |  |  |  | 11-006 |  | APP | 12-021 |  | 09-014 |  |  | 0 | 9200 | 920000 | 100 |  |  |  |  |  | 1562055 | 07-027 | XX |  |  |  |  |  |  |  |
| 1562605LOE |  | Electrical power engineer support 2012 |  | 169d | 2012-02-01 A | 2012-09-28 A | 9-120M FS+78d | 100% |  |  | ELEC ENG [880 h] | 62,092.8 | 62,092.8 | 100 | 100 | 0 | 62092.8 | CHUDAKOV | 1 | 1 | D |  | E | EUGENE C |  |  | 11-026 | 11.24260355 | 88.75739644 |  |  | 11-006 |  |  | 12-021 | 1 |  |  |  |  |  |  |  |  |  |  |  |  |  |  |  |  |  |  |  |  |  |  |
| 1562655 |  | Cable mock up trials |  | 33d | 2012-02-01 A | 2012-03-19 A | 9-120M FS+80d | 100% |  |  | MECH TECH [136 h]; MECH ENG [34 h]; MECH DES [34 h] | 10,065.7 | 10,065.7 |  |  | 0 | 10065.7 | CHUDAKOV | 1 | 1 | D |  | H | EUGENE C |  |  | 11-026 |  |  |  |  | 11-006 |  |  | 12-021 | 1 |  |  |  |  |  |  |  |  |  |  |  |  |  |  |  |  |  |  |  |  |  |  |
| 1562660 |  | Tagger Gantry design |  | 91d | 2012-02-01 A | 2012-06-11 A | 9-120M FS+80d | 100% |  |  | MECH TECH [136 h]; MECH ENG [34 h]; MECH DES [34 h] | 10,065.7 | 10,065.7 |  |  | 0 | 10065.7 | CHUDAKOV | 1 | 1 | D |  | H | EUGENE C |  |  | 11-026 |  |  |  |  | 11-006 |  |  | 12-021 | 1 |  |  |  |  |  |  |  |  |  |  |  |  |  |  |  |  |  |  |  |  |  |  |
| 1562670 |  | Materials for installation Part A |  | 169d | 2012-02-01 A | 2012-09-28 A | 9-120M FS+80d | 100% |  |  | PROCUREMENT<$50K 60 | 47,500 |  |  |  | 0 | 47500 | CHUDAKOV | 1 | 1 | D |  | D | EUGENE C |  |  | 11-026 |  |  |  |  | 11-006 |  |  | 12-021 | 1 |  |  |  | 0 | 47500 | 4750000 | 100 |  | 12-055 |  |  |  |  |  |  |  |  |  |  |  |  |  |
| 1562675 |  | Tagger LCW design |  | 91d | 2012-02-01 A | 2012-06-11 A | 9-120M FS+80d | 100% |  |  | MECH TECH [136 h]; MECH ENG [34 h]; MECH DES [34 h] | 10,065.7 | 10,065.7 |  |  | 0 | 10065.7 | CHUDAKOV | 1 | 1 | D |  | H | EUGENE C |  |  | 11-026 |  |  |  |  | 11-006 |  |  | 12-021 | 1 |  |  |  |  |  |  |  |  |  |  |  |  |  |  |  |  |  |  |  |  |  |  |
| 1562680 |  | Fiducialize and survey equipment (2012) |  | 169d | 2012-02-01 A | 2012-09-28 A | 9-120M FS+80d | 100% |  |  | MECH TECH [170 h]; MECH ENG [34 h]; SUPPLIES & MATERIALS | 12,438.88 | 9,938.88 | 100 | 100 | 0 | 12438.88 | CHUDAKOV | 1 | 1 | D |  | E | EUGENE C |  |  | 11-026 | 11.24260355 | 88.75739644 |  |  | 11-006 |  |  | 12-021 | 1 |  |  |  |  |  |  |  |  |  |  |  |  | 1562680 |  |  |  |  |  |  |  |  |  |
| 1562391 |  | Develop drift chamber gas system design |  | 212d | 2012-03-01 A | 2013-07-15 A | 9-120M FS+100d | 100% | 2012-03-01 | 2013-01-07 | MECH ENG [204 h]; MECH DES [306 h] | 29,320.33 | 29,569.49 |  |  | 14522.25 | 29044.5 | CHUDAKOV | 1 | 1 | D | 07-024 | H | EUGENE C |  |  | 11-026 |  |  |  |  | 11-006 |  |  | 12-021 |  | 09-014 | 10-042 | 12-054F |  |  |  |  |  |  |  |  |  |  |  | XX |  |  |  |  |  |  |  |
| 1562135 |  | Install Collimator #2 (Installtn) |  | 46d | 2012-03-12 A | 2012-05-14 A | 1562110 FS-20d, 1562130, 1562132 | 100% |  |  | MECH ENG [40 h]; MECH TECH [160 h]; PROCUREMENT<$50K 60 | 27,465.29 | 9,915.2 |  |  | 0 | 27465.29 | CHUDAKOV | 1 | 1 | D | 07-024 | H | EUGENE C |  |  | 11-026 |  |  |  | 11-004 |  |  | APP | 12-021F |  | 09-014 |  |  | 0 | 17550.09 | 1755009 | 100 |  |  |  |  |  |  |  |  |  |  |  |  |  |  |  |
| 1562185 |  | Install Racks Counting Room (Installtn) |  | 104d | 2012-03-12 A | 2012-08-06 A | 9-120M, 16332030 | 100% |  |  | PROCUREMENT<$50K 60; MECH TECH [160 h]; ELEC ENG [8 h] | 19,374.94 | 7,674.88 |  |  | 0 | 19374.94 | CHUDAKOV | 1 | 1 | D | 07-024 | H | EUGENE C |  |  | 11-026 |  |  |  |  | 11-006 |  | APP | 12-021F |  | 09-014 |  |  | 0 | 11700.06 | 1170006 | 100 |  |  |  |  |  | 1562185 |  |  | 10-059 |  |  |  |  |  |  |
| 1562425 |  | Evaluate Procurements 2011 (Installtn) |  | 46d | 2012-03-12 A | 2012-05-14 A | 1562423 FS-20d | 100% |  |  | MECH ENG [80 h]; MECH DES [40 h] | 7,536.4 | 7,536.4 |  |  | 0 | 7536.4 | CHUDAKOV | 1 | 1 | D | 07-024 | H | EUGENE C | 09-027 | 09-027 | 11-026 |  |  |  | 11-004 | 11-006 |  |  | 12-021F |  | 09-014 |  | 12-054F |  |  |  |  |  |  |  |  | 2 |  |  |  |  |  |  |  |  |  |  |
| 1562325 |  | Fab SOLENOID Platform #2 (Installtn) Original |  | 11d | 2012-04-02 A | 2012-04-16 A | 9-120M FS+62d, 1562425 FS-60d | 100% |  |  | MECH TECH [63.16 h]; MECH ENG [15.79 h] | 3,914.02 | 3,914.02 |  |  | 0 | 3914.0252 | CHUDAKOV | 1 | 1 | D | 07-024 | H | EUGENE C | 09-027 | 09-027 | 11-026 |  |  |  | 11-004 | 11-006 |  | APP | 12-021 |  | 09-014 | 10-042 | 12-054F |  |  |  |  |  |  |  |  |  | 1562325 |  |  |  |  |  |  |  |  |  |
| 1562395 |  | Fab Downstream Platform #3 TOF, Fcal (Installtn) |  | 64d | 2012-04-09 A | 2012-07-09 A | 9-120M FS+93d, 1562425 FS-50d, 1562394 | 100% |  |  | PROCUREMENT>$50K 69; PLABOR; MECH ENG [40 h]; MECH TECH [80 h] | 82,410.39 | 6,360 |  |  | 0 | 82410.39 | CHUDAKOV | 1 | 1 | D | 07-024 | H | EUGENE C | 09-027 | 09-027 | 11-026 |  |  |  |  | 11-006 |  | APP |  |  | 09-014 |  | 12-054F | 0 | 64350.33 | 6435033 | 100 |  |  |  |  |  | 1562395 |  |  |  |  |  |  |  |  |  |
| 1562115 |  | install Collimator Concrete Shielding (Installtn) |  | 39d | 2012-04-16 A | 2012-06-11 A | 9-120M | 100% |  |  | MECH TECH [200 h]; PROCUREMENT>$50K 69; MECH ENG [40 h]; MECH DES [40 h] | 35,849.71 | 13,619.6 |  |  | 0 | 35849.71 | CHUDAKOV | 1 | 1 | D | 07-024 | H | EUGENE C |  |  | 11-026 |  |  |  |  | 11-006 |  | APP | 12-021F |  |  |  |  | 0 | 22230.11 | 2223011 | 100 |  |  |  |  |  |  |  |  |  |  |  |  |  |  |  |
| 1562359 |  | Install Temporary Platform #5 (Installtn) |  | 21d | 2012-04-16 A | 2012-05-14 A | 9-120M | 100% |  |  | PROCUREMENT<$50K 60 | 58,500.29 |  |  |  | 0 | 58500.29 | CHUDAKOV | 1 | 1 | D | 07-024 | H | EUGENE C |  |  | 11-026 |  |  |  |  | 11-006 |  | APP |  |  | 09-014 |  | 12-054F | 0 | 58500.29 | 5850029 | 100 |  |  |  |  |  |  |  |  |  |  |  |  |  |  |  |
| 1562125 |  | Install Primary Collimator (Installtn) |  | 19d | 2012-05-14 A | 2012-06-11 A | 1553080 FS-50d, 9-120M | 100% |  |  | PROCUREMENT<$50K 60; MECH TECH [240 h]; MECH ENG [40 h] | 27,510.46 | 13,470.4 |  |  | 0 | 27510.46 | CHUDAKOV | 1 | 1 | D | 07-024 | H | EUGENE C |  |  | 11-026 |  |  |  | 11-004 |  |  | APP | 12-021F |  | 09-014 |  |  | 0 | 14040.06 | 1404006 | 100 |  |  |  |  |  |  |  |  |  |  |  |  |  |  |  |
| 1562325a |  | Fab SOLENOID Platform #2 (Installtn) Revised 2012 ETC Labor |  | 94d | 2012-06-03 A | 2012-10-15 A | 9-120M FS+184d, 1562325 | 100% | 2012-06-05 | 2012-10-15 | MECH TECH [96.84 h]; MECH ENG [24.21 h] | 6,023.61 | 6,023.61 |  |  | 0 | 6001.1748 | CHUDAKOV | 1 | 1 | D | 07-024 | H | EUGENE C | 09-027 | 09-027 | 11-026 |  |  |  | 11-004 | 11-006 |  | APP | 12-021 |  | 09-014 | 10-042 | 12-054F |  |  |  |  |  |  |  |  |  | 1562325 |  |  |  |  |  |  |  |  |  |
| 1562325b |  | Fab SOLENOID Platform #2 (Installtn) Revised 2012 ETC Procurement |  | 94d | 2012-06-03 A | 2012-10-15 A | 1562325 FS+20d, 9-120M FS+184d | 100% | 2012-06-05 | 2012-10-15 | PROCUREMENT<$50K 60 | 40,950.21 |  |  |  | 0 | 40950.21 | CHUDAKOV | 1 | 1 | D | 07-024 | D | EUGENE C | 09-027 | 09-027 | 11-026 |  |  |  | 11-004 | 11-006 |  | APP | 12-021 |  | 09-014 | 10-042 | 12-054F | 0 | 40950.21 | 4095021 | 100 |  |  |  |  |  | 1562325 |  |  |  |  |  |  |  |  |  |
| 1562430 |  | Engineering Support for Tagger Installation 2012 (Installtn) |  | 73d | 2012-06-19 A | 2012-09-28 A | 9-120M FS+174d | 100% |  |  | MECH DES [1120 h]; MECH ENG [40 h] | 56,755.2 | 56,755.2 | 100 | 100 | 0 | 56755.2 | CHUDAKOV | 1 | 1 | D | 07-024 | E | EUGENE C | 09-027 | 09-027 | 11-026 | 26.02739726 | 73.97260273 |  |  | 11-006 |  |  |  |  | 09-014 |  | 12-054F |  |  |  |  |  |  |  |  | 2 |  |  |  |  |  |  |  |  |  |  |
| 1562020M |  | Shipment of Bcal Modules (Installtn) | milestone | 0d | 2012-07-02 A | 2012-07-02 A | 1561105a | 100% | 2013-05-09 | 2013-05-09 |  |  |  |  |  |  | 0 | CHUDAKOV | 1 | 1 | D |  | M | EUGENE C |  |  | 11-026 |  |  |  |  | 11-006 |  |  | 12-021 |  |  |  |  |  |  |  |  |  |  |  |  |  |  |  |  |  | 6 | 09-043 |  |  |  |  |
| 1562190 |  | Install Pwr to Racks Counting Room (Installtn) |  | 31d | 2012-07-02 A | 2012-08-13 A | 1562185 FS-20d | 100% |  |  | PROCUREMENT>$50K 69 | 24,102.12 |  |  |  | 0 | 24102.12 | CHUDAKOV | 1 | 1 | D | 07-024 | H | EUGENE C |  |  | 11-026 |  |  |  |  | 11-006 |  | APP | 12-021F |  | 09-014 |  |  | 0 | 24102.12 | 2410212 | 100 |  |  |  |  |  |  |  |  | 10-059 |  |  |  |  |  |  |
| 1562620 |  | Procure Electrical Power cable/conduit Part A |  | 75d | 2012-07-02 A | 2012-10-15 A | 9-130M FS-60d | 100% |  |  | PROCUREMENT<$50K 60 | 4,127.6 |  |  |  | 0 | 4127.6 | CHUDAKOV | 1 | 1 | D |  | D | EUGENE C |  |  | 11-026 |  |  |  |  | 11-006 |  |  | 12-021 | 1 |  |  |  | 0 | 4127.6 | 412760 | 100 |  | 12-055 |  |  |  |  |  |  |  |  |  |  |  |  |  |
| 1562140 |  | Install Collimator Concrete Shielding (Installtn) Part A |  | 42d | 2012-08-01 A | 2012-09-28 A | 1562125 | 100% |  |  | MECH TECH [80 h]; MECH ENG [40 h]; PROCUREMENT<$50K 60 | 14,852.53 | 6,360 |  |  | 0 | 0 | CHUDAKOV | 1 | 1 | D | 07-024 | H | EUGENE C |  |  | 11-026 |  |  |  |  | 11-006 |  | APP | 12-021 |  | 09-014 |  | 12-054 | 0 | 8492.53 | 849253 | 100 |  | 12-055 |  |  |  |  |  |  |  |  |  | Aug 12 |  |  |  |
| 1562260 |  | Install Fire Protection (Installtn) Part A |  | 42d | 2012-08-01 A | 2012-09-28 A | 1562245 FS-145d | 100% |  |  | PROCUREMENT<$50K 60; PROCUREMENT>$50K 69 | 12,795.68 |  |  |  | 0 | 12795.68 | CHUDAKOV | 1 | 1 | D | 07-024 | H | EUGENE C |  |  | 11-026 |  |  |  |  | 11-006 |  | APP |  |  | 09-014 |  | 12-054F | 0 | 12795.68 | 1279568 | 100 |  | 12-055 |  |  |  | 1562260 |  |  |  |  |  |  | 11-044 |  |  |
| 1562195 |  | Install Cooling to Racks in Counting Room (Installtn) |  | 11d | 2012-08-06 A | 2012-08-20 A | 1562190 | 100% |  |  | PROCUREMENT>$50K 69 NO ESCALATION FY13 | 3,510.01 |  |  |  | 0 | 3510.01 | CHUDAKOV | 1 | 1 | D | 07-024 | H | EUGENE C |  |  | 11-026 |  |  |  |  | 11-006 |  | APP | 12-021F |  | 09-014 |  |  | 0 | 3510.01 | 351001 | 100 |  |  |  |  |  |  |  |  | 10-059 |  |  |  |  |  |  |
| 1562200 |  | Install Fire Protection to Racks in Counting Room (Installtn) |  | 11d | 2012-08-06 A | 2012-08-20 A | 1562195 | 100% |  |  | PROCUREMENT>$50K 69 | 24,870.98 |  |  |  | 0 | 24870.98 | CHUDAKOV | 1 | 1 | D | 07-024 | H | EUGENE C |  |  | 11-026 |  |  |  |  | 11-006 |  | APP | 12-021F |  | 09-014 |  | 12-054F | 0 | 24870.98 | 2487098 | 100 |  |  |  |  |  |  | 07-027 |  | 10-059 |  |  |  |  |  |  |
| 1562640 |  | Procure cable trays and hardware |  | 144d | 2012-09-03 A | 2013-08-30 A | 9-130M, 9-120M FS+184d | 100% | 2012-09-04 | 2013-04-05 | PROCUREMENT<$50K 60 | 10,319 |  |  |  | 2063.8 | 10319 | CHUDAKOV | 1 | 1 | D |  | D | EUGENE C |  |  | 11-026 |  |  |  |  | 11-006 |  |  | 12-021 | 1 |  |  | 12-054 | 0 | 10319 | 1031900 | 100 |  |  |  |  |  |  |  |  |  |  |  |  |  |  |  |
| 1562005LOE |  | FY13 Work Cordinator (Installtn) |  | 248d | 2012-10-01 A | 2013-08-30 A | 1562004LOE | 100% | 2012-10-01 | 2013-09-30 | MECH ENG [1618.06 h] | 117,082.82 | 117,082.82 | 100 | 100 | 21573.69984 | 117082.8216 | CHUDAKOV | 1 | 1 | D | 07-024 | E | EUGENE C | 09-027 | 09-027 | 11-026 | 8.06451612 | 91.93548387 |  |  |  |  |  |  |  |  |  |  |  |  |  |  |  |  |  |  |  |  |  |  |  |  |  |  |  |  |  |
| 1562013E |  | FY13 Travel (Installtn) |  | 248d | 2012-10-01 A | 2013-08-30 A | 1562012E | 100% | 2012-10-01 | 2013-09-30 | TRAVEL | 1,331.95 |  | 100 | 100 | 245.425026 | 1331.95 | CHUDAKOV | 1 | 1 | D | 07-024 | E | EUGENE C |  |  | 11-026 | 8.06451612 | 91.93548387 |  |  |  |  |  |  |  |  |  |  |  |  |  |  |  |  |  |  |  |  |  |  |  |  |  |  |  |  |  |
| 1562120 |  | Install Lead Shielding for Wall (Installtn) |  | 63d | 2012-10-01 A | 2013-02-11 A | 1562115, 9-120M FS+205d | 100% | 2012-10-01 | 2013-01-07 | MECH ENG [120 h]; MECH DES [120 h]; MECH TECH [320 h]; PROCUREMENT>$50K 69 | 51,553.71 | 29,323.6 |  |  | 0 | 50645.71 | CHUDAKOV | 1 | 1 | D | 07-024 | H | EUGENE C |  |  | 11-026 |  |  |  |  | 11-006 |  | APP | 12-021F |  |  |  |  | 0 | 22230.11 | 2223011 | 100 |  |  |  |  |  |  |  | XX |  |  |  |  |  |  |  |
| 1562140a |  | Install Collimator Concrete Shielding (Installtn) Part B |  | 22d | 2012-10-01 A | 2012-10-30 A | 1562125 | 100% |  |  | PROCUREMENT<$50K 60 | 14,446.6 |  |  |  | 0 | 0 | CHUDAKOV | 1 | 1 | D | 07-024 | H | EUGENE C |  |  | 11-026 |  |  |  |  | 11-006 |  | APP | 12-021 |  | 09-014 |  | 12-054 | 0 | 14446.6 | 1444660 | 100 |  | 12-055 |  |  |  |  |  |  |  |  |  | Aug 12 |  |  |  |
| 1562610LOE |  | Electrical power engineer support 2013 |  | 248d | 2012-10-01 A | 2013-08-30 A | 1562605LOE | 100% | 2012-10-01 | 2013-09-30 | ELEC ENG [1618.06 h] | 117,810.95 | 117,810.95 | 100 | 100 | 21707.86464 | 117810.9486 | CHUDAKOV | 1 | 1 | D |  | E | EUGENE C |  |  | 11-026 | 8.06451612 | 91.93548387 |  |  | 11-006 |  |  | 12-021 | 1 |  |  |  |  |  |  |  |  |  |  |  |  |  |  |  |  |  |  |  |  |  |  |
| 1562665 |  | Tagger Gantry Fab |  | 88d | 2012-10-01 A | 2013-01-21 A | 1562660 FS+60d, 9-130M FS-1d | 100% | 2012-10-01 | 2013-02-12 | PROCUREMENT<$50K 60 | 42,000 |  |  |  | 0 | 42000 | CHUDAKOV | 1 | 1 | D |  | D | EUGENE C |  |  | 11-026 |  |  |  |  | 11-006 |  |  | 12-021 | 1 |  |  |  | 0 | 42000 | 4200000 | 100 |  |  |  |  |  | 1562665 |  | XX |  |  |  |  |  |  |  |
| 1562670a |  | Materials for installation Part B |  | 169d | 2012-10-01 A | 2013-01-21 A | 9-120M FS+80d | 100% | 2012-10-01 | 2013-06-07 | PROCUREMENT<$50K 60 | 2,500 |  |  |  | 0 | 2500 | CHUDAKOV | 1 | 1 | D |  | D | EUGENE C |  |  | 11-026 |  |  |  |  | 11-006 |  |  | 12-021 | 1 |  |  |  | 0 | 2500 | 250000 | 100 |  | 12-055 |  |  |  |  |  |  |  |  |  |  |  |  |  |
| 1562685 |  | Fiducialize and survey equipment (2013) |  | 248d | 2012-10-01 A | 2013-08-30 A | 1562680 | 100% | 2012-10-01 | 2013-09-30 | MECH TECH [156.29 h]; MECH ENG [31.26 h]; SUPPLIES & MATERIALS | 12,009.14 | 9,429.39 | 100 | 100 | 2174.450586 | 11801.098825 | CHUDAKOV | 1 | 1 | D |  | E | EUGENE C |  |  | 11-026 | 8.06451612 | 91.93548387 |  |  | 11-006 |  |  | 12-021 | 1 |  |  |  |  |  |  |  |  |  |  |  |  | 1562685 |  |  |  |  |  |  |  |  |  |
| 1562435 |  | Engineering Support for Detector Installation 2013 (Installtn) |  | 231d | 2012-10-24 A | 2013-08-30 A | 9-130M, 1562430 FS+17d | 100% | 2012-10-24 | 2013-09-30 | MECH ENG [36.54 h]; MECH DES [365.36 h] | 20,806 | 20,806 | 100 | 100 | 4141.11312 | 20805.997645 | CHUDAKOV | 1 | 1 | D | 07-024 | E | EUGENE C | 09-027 | 09-027 | 11-026 | 8.65800865 | 91.34199134 |  | 11-004 | 11-006 |  |  |  |  | 09-014 |  | 12-054F |  |  |  |  |  |  |  |  | 2 |  |  |  |  |  |  |  |  |  |  |
| 1562440 |  | Engineering Support for Tagger Installation 2013 (Installtn) |  | 207d | 2012-10-30 A | 2013-08-30 A | 9-130M | 100% |  |  | MECH ENG [40 h]; MECH DES [400 h] | 22,778.4 | 22,778.4 | 100 | 100 | 2421.34392 | 22778.4 | CHUDAKOV | 1 | 1 | D | 07-024 | E | EUGENE C | 09-027 | 09-027 | 11-026 | 10.62801932 | 89.37198067 |  |  | 11-006 |  |  |  |  | 09-014 |  |  |  |  |  |  |  |  |  |  | 2 |  |  |  |  |  |  |  |  |  |  |
| 1562413 |  | Install Fire Protection (Installtn) |  | 6d | 2012-11-05 A | 2012-11-12 A |  | 100% |  |  | PROCUREMENT<$50K 60 |  |  |  |  | 0 | 0 | CHUDAKOV | 1 | 1 | D | 07-024 | H | EUGENE C |  |  | 11-026 |  |  |  |  | 11-006 |  | APP |  |  | 09-014 |  | 12-054 |  |  |  |  |  |  |  |  |  |  |  |  |  |  |  |  | 11-044 |  |  |
| 1562145 |  | Install Collimator Lead Shielding Wall (Installtn) |  | 10d | 2012-12-03 A | 2013-01-30 A | 1562140a, 1562120 FS-25d, 1562140, 1553095 | 100% | 2014-02-12 | 2014-02-26 | MECH TECH [80 h]; PROCUREMENT<$50K 60; MECH ENG [40 h] | 28,504.33 | 6,563.2 |  |  | 0 | 0 | CHUDAKOV | 1 | 1 | D | 07-024 | H | EUGENE C |  |  | 11-026 |  |  |  |  | 11-006 |  | APP | 12-021 |  | 09-014 |  | 12-054 | 0 | 21731.93 | 2173193 | 100 |  |  |  |  |  | 1562145 |  | XX |  |  |  |  |  |  |  |
| 1562392 |  | Procure final hardware for gas systems |  | 128d | 2013-01-07 A | 2013-08-30 A | 9-130M, 1562391 FS-20d | 100% | 2013-03-04 | 2013-08-30 | PROCUREMENT<$50K 60 | 44,935.3 |  |  |  | 30106.651 | 44935.3 | CHUDAKOV | 1 | 1 | D | 07-024 | D | EUGENE C |  |  | 11-026 |  |  |  |  | 11-006 |  |  | 12-021F |  | 09-014 | 10-042 | 12-054 | 0 | 44935.3 | 4493530 | 100 |  |  |  |  |  |  |  |  |  |  |  |  |  |  |  |
| 1562465 |  | Erect Dark Room for Fcal (Installtn) |  | 45d | 2013-01-07 A | 2013-08-28 A | 1562025M FS-225d | 100% | 2013-12-31 | 2014-03-06 | MECH ENG [112 h]; PROCUREMENT<$50K 60; MECH TECH [480 h] | 33,491.31 | 30,117.12 |  |  | 16265.895 | 32531.79 | CHUDAKOV | 1 | 1 | D | 07-024 | H | EUGENE C |  |  | 11-026 |  |  |  |  | 11-006 |  | APP |  |  | 09-014 | 10-042 | 12-054 | 0 | 2414.67 | 241467 | 100 |  |  |  |  |  |  |  |  |  |  |  |  |  | 08-016 | 10-009 |
| 1562595a |  | Installation work space infrastructure (TW's Doublewide) Part B |  | 324d | 2013-01-07 A | 2013-08-30 A | 9-110M FS+81d | 100% | 2013-02-01 | 2014-05-20 | PROCUREMENT>$50K 69 | 17,000 |  |  |  | 11084 | 17000 | CHUDAKOV | 1 | 1 | D |  | S | EUGENE C |  |  | 11-026 |  |  |  |  | 11-006 |  |  |  | 1 |  |  |  | 0 | 17000 | 1700000 | 100 | ST | 12-055 |  |  |  |  |  |  |  |  |  |  |  |  |  |

Notes:
- 1562595: Steps: Initial set-up and rent (done); set-up completion (done); Monthly Fees April 2011 (done); Monthly Fees May 2011 (done); Monthly Fees June 2011 (done); Monthly Fees July 2011 (done); Monthly Fees August 2011 (done); Monthly Fees September 2011 (done); Monthly Fees October 2011 (done); Monthly Fees November 2011 (done); Monthly Fees December 2011 (done); Monthly Fees January 2012 (done); Monthly Fees February 2012 (done); Monthly Fees March 2012 (done); Monthly Fees April 2012 (done); Monthly Fees May 2012 (done); Monthly Fees June 2012 (done); Monthly Fees July 2012 (done); Monthly Fees August 2012 (done); Monthly Fees September 2012 (done); Monthly Fees October 2012 (done); Monthly Fees November 2012 (done); Monthly Fees December 2012 (done)
- 1562102: Steps: Install LCW Down pipe (done); Install LCW filters/valves (done); Install LCW manifold (done); Install wall anchors for LCW (done); Install LCW pipe to collimator cave (done)
- 1562394: Steps: submit preliminary design trench rails to FM (done); submit preliminary design pltfrm to FM (done); Final drawings trench rails (done); Final Drawings Platform (done); Analysis complete platform (done); PR issued rails (done); PR issued downstream platform (done)
- 1562423: Steps: submit preliminary design Sol pltfrm to FM (done); submit preliminary design temp pltfrm to FM (done); Final drawings solenoid platform (done); Final Drawings Temporary Platform (done); Analysis complete sol platform (done); Analysis complete temp platform (done); PR issued sol platform (done); PR issued temp platform (done)
- 1562595a: Steps: Monthly Fees January 2013 (done); Monthly Fees February 2013 (done); Monthly Fees March 2013 (done); Monthly Fees April 2013 (done); Monthly Fees May 2013 (done); Monthly Fees June 2013 (done); Monthly Fees July 2013 (done); Monthly Fees August 2013 (done); Monthly Fees September 2013 (done); Monthly Fees October 2013 (done); Monthly Fees November 2013 (done); Monthly Fees December 2013 (done); Monthly Fees January 2014 (done); Monthly Fees February 2014 (done); Dismantle and remove1 (done)

| ID | Activity | Type | Duration | Start | Finish | Predecessors | Complete | Remaining | Planned start | Planned finish | Total float | Free float | Calendar | Resources | Cost | Actual cost | Remaining Material Cost Based on % Compl | Claimed Material Cost Based on % Complet | Initial Claimed Material Calc | Claimed Material Divider | Calculated Remaining Total Cost | MONTHLY EV COST | RESP - Responsibility | STRT%COMP for CM EVM | FNSH%COMP for CM EVM | HALL D Related Milestones | Advance Purchase Plan > 500K | EVMS Reporting Codes | CAM RESPONSIBLE | CR 09-014 | CR 11-006 | CR 11-026 | CR 11-044 | CR 12-021 | CR 12-054 | CR 07-024 | CR 07-027 | 12 GeV 1st level Critical Path | Specification | CR 12-055 | MARCH!!! | CR 09-045 | CR 11-049 | Milestone Level | CR 11-030 | CR 08-016 | Activities with Steps | CR 11-004 | CR 10-007 | CR 10-009 | CR 10-042 | CR 09-027 | CR 09-027 Repair | CR 08-052 | ReBaseline Actuals Adjustment | LOE Divider | LOE Multiplier | Original Activity ID Rebaseline | PRIOR MONTH EV COST | BOE Expenses | CR 13-015 | Post Rebaseline | Obligated Prior to Rebaseline | BOE Labor | BOE Procurement | CR 14-001 | CR 13-007 | CR 11-054 | CR 11-040 | 12 GeV 2nd level Critical Path | LOE % Pre Calc | LOE % |
| --- | --- | --- | --- | --- | --- | --- | --- | --- | --- | --- | --- | --- | --- | --- | --- | --- | --- | --- | --- | --- | --- | --- | --- | --- | --- | --- | --- | --- | --- | --- | --- | --- | --- | --- | --- | --- | --- | --- | --- | --- | --- | --- | --- | --- | --- | --- | --- | --- | --- | --- | --- | --- | --- | --- | --- | --- | --- | --- | --- | --- | --- | --- | --- | --- | --- | --- | --- | --- | --- | --- | --- | --- |
| 1562070 | Install Cooling for Tagger Electrnc's (Installtn) |  | 10d | 2013-02-01 A | 2013-02-11 A | 1562075 | 100% |  | 2013-06-21 | 2013-07-05 |  |  |  | PROCUREMENT<$50K 60 | 3,621.98 |  | 0 | 3621.98 | 362198 | 100 | 0 | 3621.98 | CHUDAKOV | 1 | 1 | D | APP | H | EUGENE C | 09-014 | 11-006 | 11-026 | 11-044 | 12-021 | 12-054 |  |  |  |  |  |  |  |  |  |  |  |  |  |  |  |  |  |  |  |  |  |  |  |  |  |  |  |  |  |  |  |  |  |  |  |  |  |
| 1562075 | Install Fire Protection for Tagger Electrnc's (Installtn) |  | 44d | 2013-02-01 A | 2013-02-11 A | 1562085 FS+19d | 100% |  | 2013-04-19 | 2013-06-20 |  |  |  | PROCUREMENT<$50K 60 | 25,353.92 |  | 0 | 25353.92 | 2535392 | 100 | 0 | 25353.92 | CHUDAKOV | 1 | 1 | D | APP | H | EUGENE C | 09-014 | 11-006 | 11-026 | 11-044 | 12-021 | 12-054 | 07-024 | 07-027 |  |  |  |  |  |  |  |  |  |  |  |  |  |  |  |  |  |  |  |  |  |  |  |  |  |  |  |  |  |  |  |  |  |  |  |
| 1562247 | Racks - Install Hall Lower Level North (N1) |  | 8d | 2013-02-01 A | 2013-03-11 A | 1562246 FS-40d | 100% |  | 2013-04-22 | 2013-05-01 |  |  |  | ELEC TECH [80 h] | 3,643.2 | 3,643.2 |  |  |  |  | 0 | 3643.2 | CHUDAKOV | 1 | 1 | D |  | H | EUGENE C | 09-014 | 11-006 | 11-026 | 11-044 |  | 12-054 | 07-024 |  | 1 |  |  |  |  |  |  |  |  |  |  |  |  |  |  |  |  |  |  |  |  |  |  |  |  |  |  |  |  |  |  |  |  |  |  |
| 1562248 | Racks - Install Hall Lower Level South (S1) |  | 10d | 2013-02-01 A | 2013-03-11 A | 1562247 FS-40d | 100% |  | 2013-05-02 | 2013-05-15 |  |  |  | ELEC TECH [80 h] | 3,643.2 | 3,643.2 |  |  |  |  | 0 | 3643.2 | CHUDAKOV | 1 | 1 | D |  | H | EUGENE C | 09-014 | 11-006 | 11-026 | 11-044 |  | 12-054 | 07-024 |  | 1 |  |  |  |  |  |  |  |  |  |  |  |  |  |  |  |  |  |  |  |  |  |  |  |  |  |  |  |  |  |  |  |  |  |  |
| 1562260a | Install Fire Protection (Installtn) Part B |  | 20d | 2013-02-01 A | 2013-02-11 A | 1562245 FS-50d | 100% |  | 2013-03-01 | 2013-03-28 |  |  |  | PROCUREMENT>$50K 69 | 11,350.9 |  | 0 | 11350.9 | 1135090 | 100 | 0 | 11350.9 | CHUDAKOV | 1 | 1 | D | APP | D | EUGENE C | 09-014 | 11-006 | 11-026 | 11-044 |  | 12-054F | 07-024 |  |  | 1562260 | 12-055 | XX |  |  |  |  |  |  |  |  |  |  |  |  |  |  |  |  |  |  |  |  |  |  |  |  |  |  |  |  |  |  |  |
| 1562420 | Install Supprt Electrnc's Platform #3 (Installtn) |  | 45d | 2013-02-05 A | 2013-02-18 A | 1542055 FS-1d, 1542045, 1542013E | 100% |  | 2013-04-05 | 2013-06-07 |  |  |  | PLABOR; ELEC TECH |  |  |  |  |  |  | 0 | 0 | CHUDAKOV | 1 | 1 | D |  | H | EUGENE C |  | 11-006 | 11-026 |  | 12-021 | 12-054 | 07-024 | 07-027 |  |  |  |  | 09-045 | 11-049 |  |  |  |  |  |  |  |  |  |  |  |  |  |  |  |  |  |  |  |  |  |  |  |  |  |  |  |  |  |
| 1562345 | Install Fire Protection (Installtn) |  | 20d | 2013-02-06 A | 2013-02-18 A |  | 100% |  | 2013-08-06 | 2013-09-03 |  |  |  | PROCUREMENT>$50K 69 | 24,146.57 |  | 0 | 24146.57 | 2414657 | 100 | 0 | 0 | CHUDAKOV | 1 | 1 | D | APP | H | EUGENE C | 09-014 | 11-006 | 11-026 | 11-044 |  | 12-054 | 07-024 |  |  |  |  |  |  |  |  |  |  |  |  |  |  |  |  |  |  |  |  |  |  |  |  |  |  |  |  |  |  |  |  |  |  |  |  |
| 1562010M | Tagger Magnets Fabbed (Installtn) | milestone | 0d | 2013-02-11 A | 2013-02-11 A | 15511105 | 100% |  | 2013-10-15 | 2013-10-15 |  |  |  |  |  |  |  |  |  |  |  | 0 | CHUDAKOV | 1 | 1 | D |  | M | EUGENE C | 09-014 | 11-006 | 11-026 |  |  |  |  |  |  |  |  |  |  |  | 6 | 11-030 |  |  |  |  |  |  |  |  |  |  |  |  |  |  |  |  |  |  |  |  |  |  |  |  |  |  |  |
| 1562050 | Install Tagger Pwr Supply (Installtn) |  | 38d | 2013-03-01 A | 2013-08-30 A | 9-130M FS+110d, 1562430 FS-47d | 100% |  | 2013-04-01 | 2013-05-22 |  |  |  | PROCUREMENT<$50K 60; ELEC ENG [16 h]; ELEC TECH [480 h] | 35,097.45 | 23,024.16 | 0 | 12073.29 | 1207329 | 100 | 17548.725 | 35097.45 | CHUDAKOV | 1 | 1 | D | APP | H | EUGENE C | 09-014 | 11-006 | 11-026 |  | 12-021 | 12-054 | 07-024 |  |  | 1562050 |  | XX |  |  |  |  |  |  |  |  |  |  |  |  |  |  |  |  |  |  |  |  |  |  |  |  |  |  |  |  |  |  |  |
| 1562045 | Install Tagger Magnets & Chamber (Installtn) |  | 45d | 2013-03-04 A | 2013-08-30 A | 3C-10M, 1562010M, 1562430 FS-73d | 100% |  | 2013-10-15 | 2013-12-18 |  |  |  | MECH TECH [480 h]; PROCUREMENT<$50K 60; MECH ENG [160 h] | 66,051.35 | 33,590.4 | 0 | 31390.55 | 3139055 | 100 | 19494.285 | 64980.95 | CHUDAKOV | 1 | 1 | D | APP | S | EUGENE C | 09-014 | 11-006 | 11-026 |  |  | 12-054 | 07-024 |  |  | 1562045 |  |  |  |  |  | 11-030 | 08-016 | ST |  |  |  |  |  |  |  |  |  |  |  |  |  |  |  |  |  |  |  |  |  |  |  |  |  |
| 1562400 | Racks - Install Hall Upper Level Downstream (D2) |  | 10d | 2013-03-04 A | 2013-04-15 A | 1562395, 1544075, 1562330 FS-90d | 100% |  | 2013-07-12 | 2013-07-25 |  |  |  | ELEC TECH [160 h] | 7,286.4 | 7,286.4 |  |  |  |  | 0 | 7286.4 | CHUDAKOV | 1 | 1 | D |  | H | EUGENE C | 09-014 | 11-006 | 11-026 | 11-044 |  | 12-054 | 07-024 |  |  |  |  |  |  |  |  |  |  |  |  |  |  |  |  |  |  |  |  |  |  |  |  |  |  |  |  |  |  |  |  |  |  |  |  |
| 1562650 | Procure power transformers |  | 76d | 2013-03-04 A | 2013-05-13 A | 9-130M FS+110d | 100% |  | 2013-04-01 | 2013-07-17 |  |  |  | PROCUREMENT<$50K 60 | 17,542.3 |  | 0 | 17542.3 | 1754230 | 100 | 0 | 17542.3 | CHUDAKOV | 1 | 1 | D |  | D | EUGENE C |  | 11-006 | 11-026 |  | 12-021 | 12-054 |  |  | 1 |  |  |  |  |  |  |  |  |  |  |  |  |  |  |  |  |  |  |  |  |  |  |  |  |  |  |  |  |  |  |  |  |  |  |
| 1562096 | Install Permanent Magnet Stand (Installtn) |  | 5d | 2013-05-01 A | 2013-05-13 A |  | 100% |  | 2014-01-16 | 2014-01-23 |  |  |  | MECH TECH [40 h] | 1,892.8 | 1,834.4 |  |  |  |  | 0 | 0 | CHUDAKOV | 1 | 1 | D |  | H | EUGENE C | 09-014 | 11-006 | 11-026 |  | 12-021 |  | 07-024 |  |  | 1562096 |  |  |  |  |  |  |  |  |  |  |  |  |  |  |  |  |  |  |  |  |  |  |  |  |  |  |  |  |  |  |  |  |  |
| 1562620a | Procure Electrical Power cable/conduit Part B |  | 120d | 2013-05-03 A | 2013-08-30 A | 9-130M FS+110d | 100% |  | 2013-06-03 | 2013-11-19 |  |  |  | PROCUREMENT<$50K 60 | 18,574.2 |  | 0 | 18574.2 | 1857420 | 100 | 14859.36 | 18574.2 | CHUDAKOV | 1 | 1 | D |  | D | EUGENE C |  | 11-006 | 11-026 |  | 12-021 |  |  |  | 1 |  | 12-055 |  |  |  |  |  |  |  |  |  |  |  |  |  |  |  |  |  |  |  |  |  |  |  |  |  |  |  |  |  |  |  |  |
| 1562060 | Survey & Align Magnets (Installtn) |  | 10d | 2013-05-06 A | 2013-08-30 A | 1562440 FS-210d, 1562045 FS-100d | 100% |  | 2013-09-09 | 2013-09-20 |  |  |  | PLABOR; MECH TECH [400 h]; MECH ENG [40 h] | 45,384.97 | 21,238.4 |  |  |  |  | 22692.485 | 45384.97 | CHUDAKOV | 1 | 1 | D |  | H | EUGENE C | 09-014 | 11-006 | 11-026 |  |  | 12-054 | 07-024 |  |  | 1562060 |  |  |  |  |  | 11-030 |  |  |  |  |  |  |  |  |  |  |  |  |  |  |  |  |  |  |  |  |  |  |  |  |  |  |  |
| 1562097 | Install Permanent Magnet (Installtn) |  | 20d | 2013-05-06 A | 2013-05-20 A | 1562096 | 100% |  | 2014-01-24 | 2014-02-21 |  |  |  | MECH TECH [160 h] | 7,571.2 | 7,337.6 |  |  |  |  | 0 | 0 | CHUDAKOV | 1 | 1 | D |  | H | EUGENE C | 09-014 | 11-006 | 11-026 |  | 12-021 |  | 07-024 |  |  | 1562097 |  |  |  |  |  |  |  |  |  |  |  |  |  |  |  |  |  |  |  |  |  |  |  |  |  |  |  |  |  |  |  |  |  |
| 1562645 | Install cable trays and hardware |  | 100d | 2013-05-06 A | 2013-08-30 A | 1562640 FS-20d | 100% |  | 2013-06-27 | 2013-11-15 |  |  |  | MECH TECH [261.12 h] | 12,104.58 | 11,974.96 |  |  |  |  | 6236.96 | 11974.9632 | CHUDAKOV | 1 | 1 | D |  | H | EUGENE C |  | 11-006 | 11-026 |  | 12-021 | 12-054 |  |  | 1 |  |  |  |  |  |  |  |  |  |  |  |  |  |  |  |  |  |  |  |  |  |  |  |  |  |  |  |  |  |  |  |  |  |  |
| 1562085 | Racks - Install Tagger |  | 10d | 2013-06-01 A | 2013-08-30 A | 3C-10M FS+194d, 9-130M FS+105d | 100% |  | 2013-07-01 | 2013-07-15 |  |  |  | ELEC TECH [40 h] | 1,821.6 | 1,821.6 |  |  |  |  | 910.8 | 1821.6 | CHUDAKOV | 1 | 1 | D |  | H | EUGENE C | 09-014 | 11-006 | 11-026 | 11-044 |  | 12-054 | 07-024 |  |  | 1562085 |  |  |  |  |  |  |  |  |  |  |  |  |  |  |  |  |  |  |  |  |  |  |  |  |  |  |  |  |  |  |  |  |  |
| 1562245 | Racks - Install Hall Lower Level Upstream (U1) |  | 10d | 2013-06-03 A | 2013-08-30 A | 1562085 FS-15d, 1544075 | 100% |  | 2013-07-16 | 2013-07-29 |  |  |  | ELEC TECH [160 h] | 7,286.4 | 7,286.4 |  |  |  |  | 3643.2 | 7286.4 | CHUDAKOV | 1 | 1 | D |  | H | EUGENE C | 09-014 | 11-006 | 11-026 | 11-044 |  | 12-054 | 07-024 |  | 1 | 1562245 |  |  |  |  |  |  |  |  |  |  |  |  |  |  |  |  |  |  |  |  |  |  |  |  |  |  |  |  |  |  |  |  |  |
| 1562625 | Install Electrical Power cable/conduit |  | 102d | 2013-06-03 A | 2013-08-30 A | 1562620a FS-80d, 1562620 FS-77d | 100% |  | 2013-07-31 | 2013-12-31 |  |  |  | MECH TECH [306 h] | 14,291.58 | 14,033.16 |  |  |  |  | 7016.58 | 14033.16 | CHUDAKOV | 1 | 1 | D |  | H | EUGENE C |  | 11-006 | 11-026 |  | 12-021 |  |  |  | 1 | 1562625 |  |  |  |  |  |  |  |  |  |  |  |  |  |  |  |  |  |  |  |  |  |  |  |  |  |  |  |  |  |  |  |  |  |
| 1562180 | Install Photon BL Tag Hall (Installtn) |  | 51d | 2013-07-01 A | 2013-08-30 A | 1562098 FS-80d | 100% |  | 2013-10-02 | 2013-12-13 |  |  |  | MECH TECH [120 h]; PROCUREMENT<$50K 60 | 8,696.73 | 5,503.2 | 0 | 3018.33 | 301833 | 100 | 8521.53 | 8521.53 | CHUDAKOV | 1 | 1 | D | APP | H | EUGENE C | 09-014 | 11-006 | 11-026 |  | 12-021 | 12-054 | 07-024 |  |  | 1562180 |  |  |  |  |  |  |  |  | 11-004 |  |  |  |  |  |  |  |  |  |  |  |  |  |  |  |  |  |  |  |  |  |  |  |  |
| 1562330 | Racks - Install Hall Upper Level Upstream (U2) |  | 10d | 2013-07-01 A | 2013-08-30 A | 1544075, 1562325, 1562325b, 1562248, 1562325a, 9-130M FS+165d | 100% |  | 2013-08-01 | 2013-08-14 |  |  |  | ELEC TECH [160 h] | 7,286.4 | 7,286.4 |  |  |  |  | 7286.4 | 7286.4 | CHUDAKOV | 1 | 1 | D | APP | H | EUGENE C | 09-014 | 11-006 | 11-026 | 11-044 |  | 12-054 | 07-024 |  |  |  |  |  |  |  |  |  |  |  |  |  |  |  |  |  |  |  |  |  |  |  |  |  |  |  |  |  |  |  |  |  |  |  |  |
| 1562405 | Install Pwr to Racks Platform #3 (Installtn) |  | 45d | 2013-07-01 A | 2013-08-30 A | 1562400 | 100% |  | 2013-08-01 | 2013-10-03 |  |  |  | PROCUREMENT<$50K 60 | 24,146.57 |  | 0 | 24146.57 | 2414657 | 100 | 24146.57 | 24146.57 | CHUDAKOV | 1 | 1 | D | APP | H | EUGENE C | 09-014 | 11-006 | 11-026 | 11-044 |  | 12-054 | 07-024 |  |  |  |  |  |  |  |  |  |  |  |  |  |  |  |  |  |  |  |  |  |  |  |  |  |  |  |  |  |  |  |  |  |  |  |  |
| 1562470 | Register Single Channel FCAL Detector to Readout (Installtn) |  | 65d | 2013-07-01 A | 2013-08-30 A | 15222105 FS+10d | 100% |  | 2013-08-01 | 2013-10-31 |  |  |  | MECH TECH [160 h]; MECH ENG [56 h] | 11,518.19 | 11,389.76 |  |  |  |  | 11389.76 | 11389.76 | CHUDAKOV | 1 | 1 | D |  | H | EUGENE C | 09-014 | 11-006 | 11-026 |  |  | 12-054 | 07-024 |  |  |  |  |  |  |  |  |  |  |  |  | 10-007 | 10-009 | 10-042 |  |  |  |  |  |  |  |  |  |  |  |  |  |  |  |  |  |  |  |  |  |
| 1562475 | Cables - Install on Trays Detector to Racks FCAL |  | 65d | 2013-07-01 A | 2013-08-30 A | 1562465 FS-45d, 1547200, 1562470 FS-65d, 15222100a FS-60d | 100% |  | 2013-08-01 | 2013-10-31 |  |  |  | ELEC TECH [88.62 h] | 4,081.22 | 4,035.75 |  |  |  |  | 10929.6 | 4035.7548 | CHUDAKOV | 1 | 1 | D | APP | H | EUGENE C | 09-014 | 11-006 | 11-026 |  |  | 12-054F | 07-024 |  |  |  |  |  |  |  |  |  |  |  |  |  |  |  |  |  |  |  |  |  |  |  |  |  |  |  |  |  |  |  |  |  |  |  |  |
| 1562250 | Install Pwr to Racks Platform #1 (Installtn) |  | 20d | 2013-07-15 A | 2013-08-30 A | 1562245 FS-15d | 100% |  | 2013-08-15 | 2013-09-12 |  |  |  | ELEC TECH [320 h]; PROCUREMENT>$50K 69 | 37,512.05 | 14,572.8 | 0 | 22939.25 | 2293925 | 100 | 37512.05 | 37512.05 | CHUDAKOV | 1 | 1 | D | APP | H | EUGENE C | 09-014 | 11-006 | 11-026 | 11-044 |  | 12-054 | 07-024 |  | 1 |  |  |  |  |  |  |  |  |  |  |  |  |  |  |  |  |  |  |  |  |  |  |  |  |  |  |  |  |  |  |  |  |  |  |
| 1562061 | Field Map Tagging Magnet (Installtn) |  | 60d | 2013-08-01 A | 2013-08-30 A | 1562045, 15511095b, 1562060, 15511095a, 15511095, 1562055, 1562440 FS-200d | 100% |  | 2013-09-09 | 2013-12-03 |  |  |  | PD UNIV STUDNT [234.67 h] | 2,643.95 | 2,583.72 |  |  |  |  | 19377.6 | 2583.7167 | CHUDAKOV | 1 | 1 | D |  | H | EUGENE C | 09-014 | 11-006 | 11-026 |  |  | 12-054 | 07-024 |  |  | 1562061 |  |  |  |  |  | 11-030 |  |  |  |  |  |  |  |  |  |  |  |  |  |  |  |  |  |  |  |  |  |  |  |  |  |  |  |
| 1562225 | Mount Bcal Modules in Solenoid (Installtn) |  | 28d | 2013-08-01 A | 2013-08-30 A | 151173n, 12361010, 15221156n, 15221155b, 15221180, 1562435 FS-229d, 15221155a, 15221180a, 1561155a, 1562020M, 1561155b | 100% |  | 2013-08-01 | 2013-09-10 |  |  |  | MECH DES [30 h]; PROCUREMENT>$50K 69; MECH TECH [435 h]; MECH ENG [30 h] | 23,611.2 | 23,611.2 |  |  |  |  | 95470.05 | 23611.2 | CHUDAKOV | 1 | 1 | D | APP | H | EUGENE C | 09-014 | 11-006 | 11-026 |  | 12-021 | 12-054 | 07-024 |  | 1 | 1562225 |  |  |  |  |  |  |  |  | 11-004 |  |  | 10-042 | 09-027 | 09-027 |  |  |  |  |  |  |  |  |  |  |  |  |  |  |  |  |  |  |  |
| 1562335 | Install Pwr to Racks Platform #2 (Installtn) |  | 45d | 2013-08-15 A | 2013-08-30 A | 1562330 | 100% |  | 2013-08-15 | 2013-10-17 |  |  |  | PROCUREMENT>$50K 69 | 36,219.88 |  | 0 | 36219.88 | 3621988 | 100 | 36219.88 | 36219.88 | CHUDAKOV | 1 | 1 | D | APP | H | EUGENE C | 09-014 | 11-006 | 11-026 | 11-044 |  | 12-054 |  |  |  |  |  |  |  |  |  |  |  |  |  |  |  |  |  |  |  |  |  |  |  |  |  |  |  |  |  |  |  |  |  |  |  |  |  |
| 1562015M | Assy of CDC (Installtn) | milestone | 0d | 2013-08-30 A | 2013-08-30 A | 1561125 | 100% |  | 2014-01-21 | 2014-01-21 |  |  |  |  |  |  |  |  |  |  |  | 0 | CHUDAKOV | 1 | 1 | D |  | M | EUGENE C |  | 11-006 | 11-026 |  |  | 12-054 |  |  |  |  |  |  |  |  | 6 |  |  |  |  |  |  |  |  |  |  |  |  |  |  |  |  |  |  |  |  |  |  |  |  |  |  |  |  |
| 1562025M | Assy of Fcal (Installtn) | milestone | 0d | 2013-08-30 A | 2013-08-30 A | 15222004, 15222105 FS+10d | 100% |  | 2013-09-03 | 2013-09-03 |  |  |  |  |  |  |  |  |  |  |  | 0 | CHUDAKOV | 1 | 1 | D |  | M | EUGENE C | 09-014 | 11-006 | 11-026 |  |  | 12-054 |  |  |  |  |  |  |  |  | 6 |  |  |  |  | 10-007 | 10-009 | 10-042 |  |  |  |  |  |  |  |  |  |  |  |  |  |  |  |  |  |  |  |  |  |
| 1562065 | Install Pwr for Tagger Electrnc's (Installtn) |  | 20d | 2013-08-30 A | 2013-08-30 A | 1562070 | 100% |  | 2013-10-14 | 2013-11-08 |  |  |  | PROCUREMENT<$50K 60 | 6,036.66 |  | 0 | 6036.66 | 603666 | 100 | 6036.66 | 6036.66 | CHUDAKOV | 1 | 1 | D | APP | H | EUGENE C | 09-014 | 11-006 | 11-026 | 11-044 | 12-021 | 12-054 |  |  |  | 1562065 |  |  |  |  |  |  |  |  |  |  |  |  |  |  |  |  |  |  |  |  |  |  |  |  |  |  |  |  |  |  |  |  |  |
| 1562090 | Install Tagger Electrnc's (Installtn) |  | 10d | 2013-08-30 A | 2013-08-30 A | 1562085 | 100% |  | 2013-09-17 | 2013-09-30 |  |  |  | ELEC ENG [8 h]; ELEC TECH [240 h]; PLABOR | 16,341.39 | 11,512.08 |  |  |  |  | 16341.39 | 16341.39 | CHUDAKOV | 1 | 1 | D |  | H | EUGENE C | 09-014 | 11-006 | 11-026 | 11-044 |  | 12-054 | 07-024 |  |  |  |  |  |  |  |  |  |  |  |  |  |  |  |  |  |  |  |  |  |  |  |  |  |  |  |  |  |  |  |  |  |  |  |  |
| 1562098 | Install Tagger Quad Stand & Magnet (Installtn) |  | 21d | 2013-08-30 A | 2013-08-30 A | 15511071, 15511115, 9-130M, 15511035 FS+36d | 100% |  | 2013-09-03 | 2013-10-01 |  |  |  | MECH TECH [440 h] | 20,208.99 | 20,178.4 |  |  |  |  | 20178.4 | 20178.4 | CHUDAKOV | 1 | 1 | D |  | H | EUGENE C | 09-014 | 11-006 | 11-026 |  | 12-021F | 12-054 | 07-024 |  |  | 1562098 |  |  |  |  |  |  |  |  | 11-004 |  |  |  |  |  |  |  |  |  |  |  |  |  |  |  |  |  |  |  |  |  |  |  |  |
| 1562205 | Install Computers in Counting Room (Installtn) Part A |  | 20d | 2013-08-30 A | 2013-08-30 A | 1531052, 1531057, 1531062, 9-120M, 1531082, 1531077, 1531047, 1531087, 1531048, 1562200, 1531032, 1531070, 1531018, 1531022, 1531042, 1531012, 1531032a | 100% |  | 2013-12-03 | 2014-01-07 |  |  |  | SCIENTIST [80 h]; ELEC TECH [80 h] | 9,773.6 | 9,472 |  |  |  |  | 9472 | 9472 | CHUDAKOV | 1 | 1 | D | APP | H | EUGENE C |  | 11-006 | 11-026 |  | 12-021 | 12-054F | 07-024 |  |  |  |  |  |  |  |  |  |  |  |  |  |  | 10-042 |  |  |  |  |  |  |  |  |  |  |  |  |  |  |  |  |  |  |  |  |  |
| 1562210 | Install Supprt Electrnc's in Counting Room (Installtn) |  | 20d | 2013-08-30 A | 2013-08-30 A | 1562205 | 100% |  | 2014-01-08 | 2014-02-05 |  |  |  | PLABOR | 12,073.29 |  |  |  |  |  | 12073.29 | 12073.29 | CHUDAKOV | 1 | 1 | D |  | H | EUGENE C |  | 11-006 | 11-026 |  | 12-021 | 12-054F | 07-024 |  |  |  |  |  |  |  |  |  |  |  |  |  |  | 10-042 |  |  |  |  |  |  |  |  |  |  |  |  |  |  |  |  |  |  |  |  |  |
| 1562246 | Racks - Install Hall Lower Level Upstream South (US1) |  | 10d | 2013-08-30 A | 2013-08-30 A | 1562245 | 100% |  | 2013-09-17 | 2013-09-30 |  |  |  | ELEC TECH [80 h] | 3,643.2 | 3,643.2 |  |  |  |  | 3643.2 | 3643.2 | CHUDAKOV | 1 | 1 | D |  | H | EUGENE C | 09-014 | 11-006 | 11-026 | 11-044 |  | 12-054 | 07-024 |  | 1 |  |  |  |  |  |  |  |  |  |  |  |  |  |  |  |  |  |  |  |  |  |  |  |  |  |  |  |  |  |  |  |  |  |  |
| 1562255 | Install Cooling to Racks Platform #1 (Installtn) |  | 20d | 2013-08-30 A | 2013-08-30 A | 1562245 | 100% |  | 2013-09-17 | 2013-10-14 |  |  |  | PROCUREMENT>$50K 69 | 36,219.88 |  | 0 | 36219.88 | 3621988 | 100 | 36219.88 | 36219.88 | CHUDAKOV | 1 | 1 | D | APP | H | EUGENE C | 09-014 | 11-006 | 11-026 | 11-044 |  | 12-054 |  |  |  |  |  |  |  |  |  |  |  |  |  |  |  |  |  |  |  |  |  |  |  |  |  |  |  |  |  |  |  |  |  |  |  |  |  |
| 1562270 | Install Supprt Electrnc's, Platform #1 (Installtn) |  | 45d | 2013-08-30 A | 2013-08-30 A | 1562260a FS+81d, 1562260 FS+81d | 100% |  | 2013-09-03 | 2013-11-04 |  |  |  | ELEC TECH [240 h]; PLABOR | 19,574.23 | 10,929.6 |  |  |  |  | 19380.9 | 19380.9 | CHUDAKOV | 1 | 1 | D |  | H | EUGENE C | 09-014 | 11-006 | 11-026 | 11-044 |  | 12-054 | 07-024 | 07-027 |  | 1562270 |  |  |  |  |  |  |  |  |  |  |  | 10-042 |  |  |  |  |  |  |  |  |  |  |  |  |  |  |  |  |  |  |  |  |  |
| 1562275 | Cables - Install on Trays Detector to Racks BCAL |  | 65d | 2013-08-30 A | 2013-08-30 A | 1547175, 1547180, 1547185 FS+8d | 100% |  | 2013-09-27 | 2014-01-07 |  |  |  | ELEC TECH [73.85 h] | 3,466.92 | 3,363.13 |  |  |  |  | 21859.2 | 3363.129 | CHUDAKOV | 1 | 1 | D |  | H | EUGENE C | 09-014 | 11-006 | 11-026 |  | 12-021 | 12-054 | 07-024 |  | 1 | 1562275 |  |  |  |  |  |  |  |  |  |  |  | 10-042 |  |  |  |  |  |  |  |  |  |  |  |  |  |  |  |  |  |  |  |  |  |
| 1562360 | Install FDC on Platform (Installtn) |  | 6d | 2013-08-30 A | 2013-08-30 A | 1561140, 1561145 FS-8d | 100% |  | 2013-11-20 | 2013-11-27 |  |  |  | PROCUREMENT<$50K 60; MECH TECH [120 h]; MECH ENG [24 h] | 11,092.46 | 7,239.84 | 0 | 3621.98 | 362198 | 100 | 10861.82 | 10861.82 | CHUDAKOV | 1 | 1 | D | APP | H | EUGENE C | 09-014 | 11-006 | 11-026 |  |  | 12-054 | 07-024 |  |  | 1562360 |  |  |  |  |  |  |  |  |  |  |  | 10-042 |  |  |  |  |  |  |  |  |  |  |  |  |  |  |  |  |  |  |  |  |  |
| 1562365 | Alignment of FDC (Installtn) |  | 10d | 2013-08-30 A | 2013-08-30 A | 1562360 FS+6d | 100% |  | 2013-12-10 | 2013-12-30 |  |  |  | MECH TECH [120 h]; MECH ENG [40 h] | 8,665.2 | 8,397.6 |  |  |  |  | 8397.6 | 8397.6 | CHUDAKOV | 1 | 1 | D |  | H | EUGENE C | 09-014 | 11-006 | 11-026 |  |  | 12-054 | 07-024 |  |  | 1562365 |  |  |  |  |  |  |  |  |  |  |  | 10-042 |  |  |  |  |  |  |  |  |  |  |  |  |  |  |  |  |  |  |  |  |  |
| 1562370 | Cables - Install on Trays Detector to Racks FDC |  | 65d | 2013-08-30 A | 2013-08-30 A | 1547160, 1547170, 1547165, 1562365 FS-50d | 100% |  | 2013-10-11 | 2014-01-22 |  |  |  | ELEC TECH [228.92 h] | 10,756.95 | 10,425.02 |  |  |  |  | 10929.6 | 10425.0168 | CHUDAKOV | 1 | 1 | D | APP | H | EUGENE C | 09-014 | 11-006 | 11-026 |  | 12-021 | 12-054 | 07-024 |  |  |  |  |  |  |  |  |  |  |  |  |  |  | 10-042 |  |  | 08-052 |  |  |  |  |  |  |  |  |  |  |  |  |  |  |  |  |  |  |
| 1562393 | Install/test gas systems |  | 80d | 2013-08-30 A | 2013-08-30 A | 1562392 FS-106d, 9-130M FS+130d | 100% |  | 2013-09-03 | 2014-01-02 |  |  |  | SCIENTIST [68 h]; MECH ENG [136 h]; MECH TECH [408 h]; MECH DES [136 h] | 41,229.76 | 40,266.88 |  |  |  |  | 40266.88 | 40266.88 | CHUDAKOV | 1 | 1 | D |  | H | EUGENE C | 09-014 | 11-006 | 11-026 |  | 12-021 | 12-054 | 07-024 |  |  | 1562393 |  |  |  |  |  |  |  |  |  |  |  | 10-042 |  |  |  |  |  |  |  |  |  |  |  |  |  |  |  |  |  |  |  |  |  |
| 1562630 | Install nitrogen lines in hall D |  | 89d | 2013-08-30 A | 2013-08-30 A | 9-130M FS+210d | 100% |  | 2013-09-03 | 2014-01-15 |  |  |  | MECH TECH [289.2 h] | 13,590.06 | 13,262.71 |  |  |  |  | 13262.712 | 13262.712 | CHUDAKOV | 1 | 1 | D |  | H | EUGENE C |  | 11-006 | 11-026 |  | 12-021 |  |  |  | 1 |  |  |  |  |  |  |  |  |  |  |  |  |  |  |  |  |  |  |  |  |  |  |  |  |  |  |  |  |  |  |  |  |  |  |
| 1562635 | Install air lines in hall D |  | 89d | 2013-08-30 A | 2013-08-30 A | 9-130M FS+144d | 100% |  | 2013-09-03 | 2014-01-15 |  |  |  | MECH TECH [272.95 h] | 12,826.44 | 12,517.49 |  |  |  |  | 13262.712 | 12517.487 | CHUDAKOV | 1 | 1 | D |  | H | EUGENE C |  | 11-006 | 11-026 |  | 12-021 |  |  |  | 1 | 1562635 |  |  |  |  |  |  |  |  |  |  |  |  |  |  |  |  |  |  |  |  |  |  |  |  |  |  |  |  |  |  |  |  |  |
| 1562690 | Re-Baseline Actuals Adjustment |  | 1d | 2013-08-30 A | 2013-08-30 A |  | 100% |  | 2013-09-03 | 2013-09-03 |  |  |  | PROCUREMENT>$50K 69 NO ESCALATION | 397,786.01 |  | 0 | 397786.01 | 39778601 | 100 |  | 397786.01 |  |  |  |  |  |  |  |  |  |  |  |  |  |  |  |  |  |  |  |  |  |  |  |  |  |  |  |  |  |  |  |  | ADJ |  |  |  |  |  |  |  |  |  |  |  |  |  |  |  |  |  |
| 2562000 | Procured Labor (Bill Vulcan) |  | 20d | 2013-09-03 A | 2013-09-30 A | 9-130M FS+228d | 100% |  | 2013-10-01 | 2013-10-28 |  |  | 8/5 M-F w/JLAB Holidays ReBaseline | PROCUREMENT<$50K 60 | 2,607.7 |  | 0 | 2607.7 | 260770 | 100 |  | 0 | CHUDAKOV | 1 | 1 | D |  | E | EUGENE C |  |  | 11-026 |  |  |  | 07-024 |  |  |  |  |  |  |  |  |  |  |  |  |  |  |  |  |  |  |  | 100 | 100 | 2562013E | 2607.7 | PE | 13-015 | PR | OB |  |  |  |  |  |  |  |  |  |
| 2562005LOE | FY13 Work Cordinator (Installtn) |  | 20d | 2013-09-03 A | 2013-09-30 A | 9-130M FS+228d | 100% |  | 2013-10-01 | 2013-10-28 |  |  | 8/5 M-F w/JLAB Holidays ReBaseline | MECH ENG [141.88 h] | 10,594.18 | 10,266.44 |  |  |  |  |  | 0 | CHUDAKOV | 1 | 1 | D |  | E | EUGENE C |  |  | 11-026 |  |  |  | 07-024 |  |  |  |  |  |  |  |  |  |  |  |  |  |  |  | 09-027 | 09-027 |  |  | 100 | 100 | 2562005LOE | 10266.4368 |  | 13-015 | PR |  | PE |  |  |  |  |  |  |  |  |
| 2562013E | FY13 Travel (Installtn) |  | 20d | 2013-09-03 A | 2013-09-30 A | 9-130M FS+228d | 100% |  | 2013-10-01 | 2013-10-28 |  |  | 8/5 M-F w/JLAB Holidays ReBaseline | TRAVEL | 134.2 |  |  |  |  |  |  | 0 | CHUDAKOV | 1 | 1 | D |  | E | EUGENE C |  |  | 11-026 |  |  |  | 07-024 |  |  |  |  |  |  |  |  |  |  |  |  |  |  |  |  |  |  |  | 100 | 100 | 2562013E | 134.2 | PE | 13-015 | PR |  |  |  |  |  |  |  |  |  |  |
| 2562045 | Install Tagger Magnets & Chamber (Installtn) FY13 |  | 20d | 2013-09-03 A | 2013-11-15 | 9-130M FS+228d | 50% | 11d | 2013-10-01 | 2013-10-28 | 124d | 0d | 8/5 M-F w/JLAB Holidays ReBaseline | MECH TECH [70.14 h]; MECH ENG [18.58 h]; SUPPLIES & MATERIALS; PLABOR; ELEC DES [1.86 h] | 7,740.43 | 3,005.17 |  |  |  |  |  | 0 | CHUDAKOV | 1 | 1 | D | APP | S | EUGENE C | 09-014 | 11-006 | 11-026 |  |  | 12-054 | 07-024 |  |  |  |  |  |  |  |  | 11-030 | 08-016 | ST |  |  |  |  |  |  |  |  |  |  | 2562045 | 3796.006897 | EJ | 13-015 | PR |  | PE | EJ |  |  |  |  |  |  |  |
| 2562045a | Install Tagger Magnets & Chamber (Installtn) FY14 |  | 11d | 2013-09-03 A | 2013-11-15 | 2562045 FS-20d | 50% | 11d | 2013-10-01 | 2013-10-15 | 124d | 0d | 8/5 M-F w/JLAB Holidays ReBaseline | MECH TECH [38.58 h]; MECH ENG [10.22 h]; SUPPLIES & MATERIALS; PLABOR; ELEC DES [1.02 h] | 4,308.77 | 1,652.88 |  |  |  |  |  | 0 | CHUDAKOV | 1 | 1 | D | APP | S | EUGENE C | 09-014 | 11-006 | 11-026 |  |  | 12-054 | 07-024 |  |  |  |  |  |  |  |  | 11-030 | 08-016 | ST |  |  |  |  |  |  |  |  |  |  | 2562045 | 2154.3835795 | EJ | 13-015 | PR |  | PE | EJ | 14-001 |  |  |  |  |  |  |
| 2562050 | Install Tagger Pwr Supply (Installtn) FY13 |  | 20d | 2013-09-03 A | 2013-11-12 | 9-130M FS+228d | 30% | 8d | 2013-10-01 | 2013-10-28 | 17d | 0d | 8/5 M-F w/JLAB Holidays ReBaseline | ELEC ENG [5.6 h]; ELEC TECH [145.6 h]; SUPPLIES & MATERIALS; MECH TECH [21 h]; MECH ENG [8.4 h] | 10,239.67 | 6,149.46 |  |  |  |  |  | 0 | CHUDAKOV | 1 | 1 | D | APP | S | EUGENE C | 09-014 | 11-006 | 11-026 |  | 12-021 | 12-054 | 07-024 |  |  |  |  |  |  |  |  |  |  | ST |  |  |  |  |  |  |  |  |  |  | 2562050 | 2989.6482 | EJ | 13-015 | PR |  | PE |  |  |  |  |  |  |  |  |
| 2562050a | Install Tagger Pwr Supply (Installtn) FY14 |  | 8d | 2013-09-03 A | 2013-11-12 | 2562050 FS-20d | 30% | 8d | 2013-10-01 | 2013-10-10 | 17d | 0d | 8/5 M-F w/JLAB Holidays ReBaseline | ELEC ENG [2.24 h]; ELEC TECH [58.24 h]; SUPPLIES & MATERIALS; MECH TECH [8.4 h]; MECH ENG [3.36 h] | 4,113.18 | 2,459.78 |  |  |  |  |  | 0 | CHUDAKOV | 1 | 1 | D | APP | S | EUGENE C | 09-014 | 11-006 | 11-026 |  | 12-021 | 12-054 | 07-024 |  |  |  |  |  |  |  |  |  |  | ST |  |  |  |  |  |  |  |  |  |  | 2562050 | 1233.9534 | EJ | 13-015 | PR |  | PE |  | 14-001 |  |  |  |  |  |  |
| 2562063 | Fab field map fixture tagging magnet |  | 32d | 2013-09-03 A | 2013-10-21 A | 9-130M FS+228d | 100% |  | 2013-10-01 | 2013-11-13 |  |  | 8/5 M-F w/JLAB Holidays ReBaseline | PROCUREMENT<$50K 60 NO ESCALATION FY14 | 1,840 |  | 0 | 1840 | 184000 | 100 |  | 1840 | CHUDAKOV | 1 | 1 | D |  | D | EUGENE C |  |  |  |  |  |  |  |  |  |  |  |  |  |  |  |  |  |  |  |  |  |  |  |  |  |  |  |  | 2562063 |  |  | 13-015 | PR | OB-2 |  | EJ |  | 13-007 |  |  |  |  |  |
| 2562225 | Mount Bcal in Solenoid (Installtn) |  | 20d | 2013-09-03 A | 2013-09-23 A | 251195 FS-4d | 100% |  | 2013-10-01 | 2013-10-28 |  |  | 8/5 M-F w/JLAB Holidays ReBaseline | SUPPLIES & MATERIALS; MECH TECH [208 h]; MECH ENG [40 h]; MECH DES [40 h] | 17,881.36 | 14,421.68 |  |  |  |  |  | 0 | CHUDAKOV | 1 | 1 | D | APP | S | EUGENE C | 09-014 | 11-006 | 11-026 |  | 12-021 | 12-054 | 07-024 |  | 1 |  |  |  |  |  |  |  |  | ST | 11-004 |  |  | 10-042 | 09-027 | 09-027 |  |  |  |  | 2562225 | 17421.68 | EJ | 13-015 | PR |  | EJ |  |  | 13-007F | 11-054 |  |  |  |  |
| 2562230 | Attach readout wedges to the BCAL modules in situ (Installtn) FY13 |  | 20d | 2013-09-03 A | 2014-02-11 | 2546362 FS-20d, 2562225 FS-25d | 25% | 62d | 2013-10-01 | 2013-10-28 | 151d | 0d | 8/5 M-F w/JLAB Holidays ReBaseline | MECH DES [11.69 h]; MECH TECH [122.33 h]; MECH ENG [11.69 h]; SUPPLIES & MATERIALS | 7,943 | 2,930.93 |  |  |  |  |  | -5789.107821 | CHUDAKOV | 1 | 1 | D | APP | S | EUGENE C | 09-014 | 11-006 | 11-026 |  | 12-021 | 12-054 | 07-024 |  | 1 |  |  |  |  |  |  |  | 08-016 | ST |  |  |  | 10-042 |  |  |  |  |  |  | 2562230 | 7718.810428 | EJ | 13-015 | PR |  | PE |  |  | 13-007F | 11-054 | 11-040 |  |  |  |
| 2562230a | Attach readout wedges to the BCAL modules in situ (Installtn) FY14 |  | 57d | 2013-09-03 A | 2014-02-11 | 2562230 FS-80d | 25% | 62d | 2013-10-01 | 2013-12-20 | 151d | 0d | 8/5 M-F w/JLAB Holidays ReBaseline | MECH DES [33.31 h]; MECH TECH [348.67 h]; MECH ENG [33.31 h]; SUPPLIES & MATERIALS | 22,700.36 | 8,353.47 |  |  |  |  |  | -17025.26907225 | CHUDAKOV | 1 | 1 | D | APP | S | EUGENE C | 09-014 | 11-006 | 11-026 |  | 12-021 | 12-054 | 07-024 |  | 1 |  |  |  |  |  |  |  | 08-016 | ST |  |  |  | 10-042 |  |  |  |  |  |  | 2562230 | 22700.358763 | EJ | 13-015 | PR |  | PE |  | 14-001 | 13-007F | 11-054 | 11-040 |  |  |  |
| 2562330 | Racks - Install Hall Upper Level Upstream (U2) |  | 21d | 2013-09-03 A | 2013-10-21 A | 2562225 FS-20d | 100% |  | 2013-10-01 | 2013-10-29 |  |  | 8/5 M-F w/JLAB Holidays ReBaseline | ELEC TECH [2.4 h]; SUPPLIES & MATERIALS; MECH TECH [74.4 h]; MECH DES [4.8 h]; MECH ENG [2.4 h] | 4,118.84 | 4,019.69 |  |  |  |  |  | 2276.32464 | CHUDAKOV | 1 | 1 | D | APP | S | EUGENE C | 09-014 | 11-006 | 11-026 | 11-044 |  | 12-054 | 07-024 |  |  |  |  |  |  |  |  |  |  | ST |  |  |  |  |  |  |  |  |  |  | 2562330 | 1717.22736 | EJ | 13-015 | PR |  | PE |  |  | 13-007F |  |  |  |  |  |
| 2562392 | Procure final hardware for Drift Chamber gas systems (Previously Obligated) |  | 29d | 2013-09-03 A | 2013-10-21 A | 9-130M FS+228d | 100% |  | 2013-10-01 | 2013-11-08 |  |  | 8/5 M-F w/JLAB Holidays ReBaseline | PROCUREMENT<$50K 60 NO ESCALATION FY14 | 26,348 |  | 0 | 26348 | 2634800 | 100 |  | 26348 | CHUDAKOV | 1 | 1 | D |  | D | EUGENE C | 09-014 | 11-006 | 11-026 |  | 12-021F | 12-054 | 07-024 |  |  |  |  |  |  |  |  |  |  |  |  |  |  | 10-042 |  |  |  |  |  |  | 2562392 |  |  | 13-015 | PR | OB |  | EV |  | 13-007 |  |  |  |  |  |
| 2562392a | Procure final hardware for Drift Chamber gas systems |  | 29d | 2013-09-03 A | 2013-11-13 | 9-130M FS+228d | 40% | 9d | 2013-10-01 | 2013-11-08 | 24d | 0d | 8/5 M-F w/JLAB Holidays ReBaseline | PROCUREMENT<$50K 60 NO ESCALATION FY14 | 26,852 |  | 16111.2 | 10740.8 | 1074080 | 100 |  | 6981.52 | CHUDAKOV | 1 | 1 | D |  | D | EUGENE C | 09-014 | 11-006 | 11-026 |  | 12-021F | 12-054 | 07-024 |  |  |  |  |  |  |  |  |  |  |  |  |  |  | 10-042 |  |  |  |  |  |  | 2562392 | 3759.28 |  | 13-015 | PR | OB-2 |  | EV |  | 13-007 |  |  |  |  |  |
| 2562435 | Engineering Support for Detector Installation 2013 (Installtn) |  | 20d | 2013-09-03 A | 2013-09-30 A | 9-130M FS+228d | 100% |  | 2013-10-01 | 2013-10-28 |  |  | 8/5 M-F w/JLAB Holidays ReBaseline | MECH ENG [28.45 h]; MECH DES [38.11 h] | 4,079.38 | 3,953.07 |  |  |  |  |  | 0 | CHUDAKOV | 1 | 1 | D |  | E | EUGENE C | 09-014 | 11-006 | 11-026 |  |  | 12-054F | 07-024 |  |  |  |  |  |  |  |  |  |  |  | 11-004 |  |  |  | 09-027 | 09-027 |  |  | 100 | 100 | 2562435 | 3953.068175 |  | 13-015 | PR |  | PE |  |  | 13-007F |  |  | 2 |  |  |
| 2562440 | Engineering Support for Tagger Installation 2013 (Installtn) |  | 20d | 2013-09-03 A | 2013-09-30 A | 9-130M FS+228d | 100% |  | 2013-10-01 | 2013-10-28 |  |  | 8/5 M-F w/JLAB Holidays ReBaseline | MECH ENG [5.37 h]; MECH DES [32.21 h] | 2,053.32 | 1,989.7 |  |  |  |  |  | 0 | CHUDAKOV | 1 | 1 | D |  | E | EUGENE C | 09-014 | 11-006 | 11-026 |  |  |  | 07-024 |  |  |  |  |  |  |  |  |  |  |  |  |  |  |  | 09-027 | 09-027 |  |  | 100 | 100 | 2562440 | 1989.699934 |  | 13-015 | PR |  | PE |  |  |  |  |  | 2 |  |  |
| 2562445 | Engineering Support for Installation 2013 (Installtn) |  | 20d | 2013-09-03 A | 2013-09-30 A | 9-130M FS+228d | 100% |  | 2013-10-01 | 2013-10-28 |  |  | 8/5 M-F w/JLAB Holidays ReBaseline | MECH DES [74.19 h]; MECH ENG [61.29 h] | 8,382.44 | 8,122.9 |  |  |  |  |  | 0 | CHUDAKOV | 1 | 1 | D |  | E | EUGENE C | 09-014 | 11-006 | 11-026 |  |  |  | 07-024 |  |  |  |  |  |  |  |  |  |  |  |  |  |  |  | 09-027 | 09-027 |  |  | 100 | 100 | 2562445 | 8122.896934 |  | 13-015 | PR |  | PE |  |  |  |  |  | 2 | 91.93548387 | 8.06451612 |
| 2562466 | Install Dark Room for Fcal (Installtn) |  | 20d | 2013-09-03 A | 2013-12-04 | 9-130M FS+228d | 70% | 22d | 2013-10-01 | 2013-10-28 | 43d | 3d | 8/5 M-F w/JLAB Holidays ReBaseline | SUPPLIES & MATERIALS; MECH TECH [34 h]; ELEC ENG [6.8 h]; MECH ENG [13.6 h]; MECH DES [6.8 h] | 4,334.11 | 1,607.86 |  |  |  |  |  | 0 | CHUDAKOV | 1 | 1 | D | APP | S | EUGENE C | 09-014 | 11-006 | 11-026 |  |  | 12-054 | 07-024 |  |  |  |  |  |  |  |  |  | 08-016 | ST |  |  | 10-009 | 10-042 |  |  |  |  |  |  | 2562466 | 2958.5304 | EJ | 13-015 | PR |  | EJ |  |  | 13-007 |  |  |  |  |  |
| 2562475 | Cables - Install on Trays Detector to Racks FCAL FY13 (FY14 @ 2562475d) |  | 20d | 2013-09-03 A | 2013-09-23 A | 2562466 FS-25d | 100% |  | 2013-10-01 | 2013-10-28 |  |  | 8/5 M-F w/JLAB Holidays ReBaseline | SCIENTIST; ELEC TECH [73.84 h]; MECH TECH [73.84 h] | 6,964.33 | 6,749.43 |  |  |  |  |  | 0 | CHUDAKOV | 1 | 1 | D | APP | U | EUGENE C | 09-014 | 11-006 | 11-026 |  |  | 12-054F | 07-024 |  |  |  |  |  |  |  |  |  |  |  |  |  |  |  |  |  |  |  |  |  | 2562475 | 6749.433 |  | 13-015 | PR |  | PE |  |  | 13-007 |  |  |  |  |  |
| 2562475a | Cables - Route and Connect on Detector FCAL FY13 |  | 20d | 2013-09-03 A | 2013-09-23 A | 2562475 FS-26d | 100% |  | 2013-10-01 | 2013-10-28 |  |  | 8/5 M-F w/JLAB Holidays ReBaseline | SCIENTIST; ELEC TECH [16.41 h]; MECH TECH [16.41 h] | 1,547.63 | 1,499.87 |  |  |  |  |  | 0 | CHUDAKOV | 1 | 1 | D |  | U | EUGENE C | 09-014 | 11-006 | 11-026 |  |  |  | 07-024 |  |  |  |  |  |  |  |  |  |  |  |  |  |  |  |  |  |  |  |  |  | 2562475a | 1499.874 |  | 13-015 | PR |  | PE |  |  | 13-007 |  |  |  |  |  |
| 2562475aa | Cables - Route and Connect on Detector FCAL FY14 |  | 19d | 2013-09-03 A | 2013-09-23 A | 2562475a, 2562475d FS-26d | 100% |  | 2013-09-03 | 2013-09-27 |  |  | 8/5 M-F w/JLAB Holidays ReBaseline | SCIENTIST; ELEC TECH [15.59 h]; MECH TECH [15.59 h] | 1,424.93 | 1,424.93 |  |  |  |  |  | 0 | CHUDAKOV | 1 | 1 | D |  | U | EUGENE C | 09-014 | 11-006 | 11-026 |  |  |  | 07-024 |  |  |  |  |  |  |  |  |  |  |  |  |  |  |  |  |  |  |  |  |  | 2562475a | 1470.2929 |  | 13-015 | PR |  | PE |  | 14-001 | 13-007 |  |  |  |  |  |
| 2562475b | Cables - Route on Racks FCAL FY13 |  | 20d | 2013-09-03 A | 2013-09-23 A | 2562475aa FS-39d, 2562475a FS-39d | 100% |  | 2013-10-01 | 2013-10-28 |  |  | 8/5 M-F w/JLAB Holidays ReBaseline | SCIENTIST; ELEC TECH [20.87 h] | 980.68 | 950.42 |  |  |  |  |  | 0 | CHUDAKOV | 1 | 1 | D |  | U | EUGENE C | 09-014 | 11-006 | 11-026 |  |  |  | 07-024 |  |  |  |  |  |  |  |  |  |  |  |  |  |  |  |  |  |  |  |  |  | 2562475b | 950.4198 |  | 13-015 | PR |  | PE |  |  | 13-007 |  |  |  |  |  |
| 2562475ba | Cables - Route on Racks FCAL FY14 |  | 26d | 2013-09-03 A | 2013-09-23 A | 2562475aa FS-39d, 2562475b | 100% |  | 2013-10-01 | 2013-11-05 |  |  | 8/5 M-F w/JLAB Holidays ReBaseline | SCIENTIST; ELEC TECH [27.13 h] | 1,274.84 | 1,235.5 |  |  |  |  |  | 0 | CHUDAKOV | 1 | 1 | D |  | U | EUGENE C | 09-014 | 11-006 | 11-026 |  |  |  | 07-024 |  |  |  |  |  |  |  |  |  |  |  |  |  |  |  |  |  |  |  |  |  | 2562475b | 1274.8387 |  | 13-015 | PR |  | PE |  | 14-001 | 13-007 |  |  |  |  |  |

Notes:
- 1562045: Steps: Receive magnet (done); Install Lower pole (done); Initial Align (done); Install 2nd slab (done); Install Vacuum Chamber (done); Install Upper poles (done); Install thin Window (done); Leak Check (done); Install LCW manifold (done); Install Power cables (done); Test magnet under power (done)
- 2562045: Steps: Hook up power (done); Test systems
- 2562045a: Steps: Hook up power (done); Test systems
- 2562050: Steps: hook up LCW (done); Test systems
- 2562050a: Steps: hook up LCW (done); Test systems
- 2562225: Steps: Mount Bcal in Solenoid (Installtn) (done)
- 2562230: Steps: __make_both_ends_light_tight (done); __hookup_cooling_manifold_to_wedges; __hook_up_nitrogen_system_to_wedges; __leak_check/Test_cooling_system; __leak_check/test_nitrogen_system
- 2562230a: Steps: __make_both_ends_light_tight (done); __hookup_cooling_manifold_to_wedges; __hook_up_nitrogen_system_to_wedges; __leak_check/Test_cooling_system; __leak_check/test_nitrogen_system
- 2562330: Steps: bring racks to hall South (done); attach vertical cable management panels S (done); Cut holes for cable pass through N (done); Cut holes for cable pass through S (done)
- 2562466: Steps: install lights and power (done); Install PSS system (done); install cooling duct work and fan

| ID | Activity | Duration | Start | Finish | Predecessors | Complete | Remaining | Planned start | Planned finish | Total float | Free float | Calendar | Resources | Cost | Actual cost | Original Activity ID Rebaseline | MONTHLY EV COST | PRIOR MONTH EV COST | RESP - Responsibility | STRT%COMP for CM EVM | FNSH%COMP for CM EVM | HALL D Related Milestones | CR 07-024 | EVMS Reporting Codes | CAM RESPONSIBLE | CR 09-014 | CR 11-006 | CR 11-026 | CR 13-007 | BOE Labor | CR 13-015 | Post Rebaseline | CR 14-001 | Advance Purchase Plan > 500K | CR 12-054 | Activities with Steps | BOE Expenses | LOE % Pre Calc | LOE % | LOE Divider | LOE Multiplier | Remaining Material Cost Based on % Compl | Claimed Material Cost Based on % Complet | Initial Claimed Material Calc | Claimed Material Divider | 12 GeV 1st level Critical Path | CR 12-055 | BOE Procurement | Obligated Prior to Rebaseline | CR 12-021 | CR 11-004 | CR 11-030 | CR 10-042 | CR 09-027 | CR 09-027 Repair | CR 11-044 | 12 GeV 2nd level Critical Path | CR 07-027 | CR 09-012 | CR 09-045 | CR 11-049 |
| --- | --- | --- | --- | --- | --- | --- | --- | --- | --- | --- | --- | --- | --- | --- | --- | --- | --- | --- | --- | --- | --- | --- | --- | --- | --- | --- | --- | --- | --- | --- | --- | --- | --- | --- | --- | --- | --- | --- | --- | --- | --- | --- | --- | --- | --- | --- | --- | --- | --- | --- | --- | --- | --- | --- | --- | --- | --- | --- | --- | --- | --- |
| 2562475c | Cables - Connect to Crate Electronics FCAL FY13 | 20d | 2013-09-03 A | 2013-09-23 A | 2562475b FS-46d, 2562475ba FS-46d | 100% |  | 2013-10-01 | 2013-10-28 |  |  | 8/5 M-F w/JLAB Holidays ReBaseline | ELEC ENG [5.16 h]; ELEC TECH [10.32 h] | 872.61 | 845.67 | 2562475c | 0 | 845.6724 | CHUDAKOV | 1 | 1 | D | 07-024 | U | EUGENE C | 09-014 | 11-006 | 11-026 | 13-007 | PE | 13-015 | PR |  |  |  |  |  |  |  |  |  |  |  |  |  |  |  |  |  |  |  |  |  |  |  |  |  |  |  |  |  |
| 2562475ca | Cables - Connect to Crate Electronics FCAL FY14 | 42d | 2013-09-03 A | 2013-09-23 A | 2562475c, 2562475ba FS-46d | 100% |  | 2013-10-01 | 2013-11-27 |  |  | 8/5 M-F w/JLAB Holidays ReBaseline | ELEC ENG [10.84 h]; ELEC TECH [21.68 h] | 1,833.15 | 1,776.57 | 2562475c | 0 | 1833.1524 | CHUDAKOV | 1 | 1 | D | 07-024 | U | EUGENE C | 09-014 | 11-006 | 11-026 | 13-007 | PE | 13-015 | PR | 14-001 |  |  |  |  |  |  |  |  |  |  |  |  |  |  |  |  |  |  |  |  |  |  |  |  |  |  |  |  |
| 2562475d | Cables - Install on Trays Detector to Racks FCAL FY14 (FY13 @ 2562475) | 6d | 2013-09-03 A | 2013-09-23 A |  | 100% |  | 2013-10-01 | 2013-10-08 |  |  | 8/5 M-F w/JLAB Holidays ReBaseline | SCIENTIST; ELEC TECH [22.16 h]; MECH TECH [22.16 h] | 2,089.43 | 2,024.97 | 2562475 | 0 | 2089.43805 | CHUDAKOV | 1 | 1 | D | 07-024 | U | EUGENE C | 09-014 | 11-006 | 11-026 | 13-007 | PE | 13-015 | PR | 14-001 | APP | 12-054F |  |  |  |  |  |  |  |  |  |  |  |  |  |  |  |  |  |  |  |  |  |  |  |  |  |  |
| 2562480 | Install Pulsing Sys for Fcal (Installtn) FY13 | 20d | 2013-09-03 A | 2014-03-17 | 25222090 FS-90d, 25222085 FS-88d, 2562475 FS-30d, 25222085a FS-88d | 25% | 86d | 2013-10-01 | 2013-10-28 | 79d | 15d | 8/5 M-F w/JLAB Holidays ReBaseline | SUPPLIES & MATERIALS; SCIENTIST [4.65 h]; ELEC TECH [4.65 h]; MECH TECH [4.65 h] | 2,160.22 | 258.94 | 2562480 | 0 | 533.97475 | CHUDAKOV | 1 | 1 | D | 07-024 | S | EUGENE C | 09-014 | 11-006 | 11-026 | 13-007 | EJ | 13-015 | PR |  |  | 12-054F | ST | EJ |  |  |  |  |  |  |  |  |  |  |  |  |  |  |  |  |  |  |  |  |  |  |  |  |
| 2562480a | Install Pulsing Sys for Fcal (Installtn) FY14 | 109d | 2013-09-03 A | 2014-03-17 | 2562480 FS-120d, 2562475d FS-26d | 25% | 86d | 2013-10-01 | 2014-03-17 | 79d | 15d | 8/5 M-F w/JLAB Holidays ReBaseline | SUPPLIES & MATERIALS; SCIENTIST [25.35 h]; ELEC TECH [25.35 h]; MECH TECH [25.35 h] | 12,013.03 | 1,411.64 | 2562480 | 0 | 3003.257875 | CHUDAKOV | 1 | 1 | D | 07-024 | S | EUGENE C | 09-014 | 11-006 | 11-026 | 13-007 | EJ | 13-015 | PR | 14-001 |  | 12-054F | ST | EJ |  |  |  |  |  |  |  |  |  |  |  |  |  |  |  |  |  |  |  |  |  |  |  |  |
| 2562595a | Installation work space infrastructure (TW's Doublewide) | 267d | 2013-09-03 A | 2014-09-30 | 9-130M FS+228d | 16% | 224d | 2013-10-01 | 2014-10-28 | 250d |  | 8/5 M-F w/JLAB Holidays ReBaseline | PROCUREMENT>$50K 69 NO ESCALATION FY14 | 5,800 |  | 2562595a | 499.38 | 434.42 | CHUDAKOV | 1 | 1 | D |  | E | EUGENE C |  | 11-006 | 11-026 |  |  | 13-015 | PR |  |  |  |  |  | 83.89513108 | 16.10486891 | 100 | 100 | 4866.2 | 933.8 | 93380 | 100 | 1 | 12-055 | OB | OB |  |  |  |  |  |  |  |  |  |  |  |  |
| 2562610LOE | Electrical power engineer support 2013 | 20d | 2013-09-03 A | 2013-09-30 A | 9-130M FS+228d | 100% |  | 2013-10-01 | 2013-10-28 |  |  | 8/5 M-F w/JLAB Holidays ReBaseline | ELEC ENG [141.91 h] | 10,661.7 | 10,332.47 | 2562610LOE | 0 | 10332.4671 | CHUDAKOV | 1 | 1 | D |  | E | EUGENE C |  | 11-006 | 11-026 |  | PE | 13-015 | PR |  |  |  |  |  |  |  | 100 | 100 |  |  |  |  | 1 |  |  |  | 12-021 |  |  |  |  |  |  |  |  |  |  |  |
| 2562620a | Procure Electrical Power cable/conduit Part B FY13 | 20d | 2013-09-03 A | 2013-11-18 | 9-130M FS+228d | 50% | 12d | 2013-10-01 | 2013-10-28 | 199d | 28d | 8/5 M-F w/JLAB Holidays ReBaseline | SUPPLIES & MATERIALS | 24,064.17 |  | 2562620a | 9625.668 | 2406.417 | CHUDAKOV | 1 | 1 | D |  | D | EUGENE C |  | 11-006 | 11-026 | 13-007 |  | 13-015 | PR |  |  |  |  | CP |  |  |  |  |  |  |  |  | 1 | 12-055 |  |  | 12-021 |  |  |  |  |  |  |  |  |  |  |  |
| 2562620aa | Procure Electrical Power cable/conduit Part B FY14 | 4d | 2013-09-03 A | 2013-11-18 | 2562620a FS-40d | 50% | 12d | 2013-10-01 | 2013-10-04 | 199d | 44d | 8/5 M-F w/JLAB Holidays ReBaseline | SUPPLIES & MATERIALS | 4,966.36 |  | 2562620a | 1986.544 | 496.636 | CHUDAKOV | 1 | 1 | D |  | D | EUGENE C |  | 11-006 | 11-026 | 13-007 |  | 13-015 | PR | 14-001 |  |  |  | CP |  |  |  |  |  |  |  |  | 1 | 12-055 |  |  | 12-021 |  |  |  |  |  |  |  |  |  |  |  |
| 2562626 | Install Transformers and Panels in Hall D | 62d | 2013-09-03 A | 2013-10-21 A | 9-130M FS+228d | 100% |  | 2013-10-01 | 2014-01-08 |  |  | 8/5 M-F w/JLAB Holidays ReBaseline | PROCUREMENT<$50K 60 NO ESCALATION FY14 | 43,349 |  | 2562626 | 43349 |  | CHUDAKOV | 1 | 1 | D |  | D | EUGENE C |  | 11-006 | 11-026 | 13-007 |  | 13-015 | PR |  |  | 12-054 |  |  |  |  |  |  | 0 | 43349 | 4334900 | 100 | 1 |  | PE | OB |  |  |  |  |  |  |  |  |  |  |  |  |
| 2562640 | Procure cable trays and hardware | 20d | 2013-09-03 A | 2013-10-21 A | 9-130M FS+228d | 100% |  | 2013-10-01 | 2013-10-28 |  |  | 8/5 M-F w/JLAB Holidays ReBaseline | PROCUREMENT<$50K 60 | 1,238.28 |  | 2562640 | 928.71 | 309.57 | CHUDAKOV | 1 | 1 | D |  | S | EUGENE C |  | 11-006 | 11-026 |  |  | 13-015 | PR |  |  | 12-054 | ST |  |  |  |  |  | 0 | 1238.28 | 123828 | 100 | 1 |  | PE | OB-2 | 12-021 |  |  |  |  |  |  |  |  |  |  |  |
| 2562645 | Install cable trays and hardware FY13 | 20d | 2013-09-03 A | 2013-11-20 | 2562640 FS-20d | 20% | 14d | 2013-10-01 | 2013-10-28 | 121d | 16d | 8/5 M-F w/JLAB Holidays ReBaseline | MECH TECH [28.21 h] | 1,334.9 | 992.58 | 2562645 | 0 | 258.74212 | CHUDAKOV | 1 | 1 | D |  | S | EUGENE C |  | 11-006 | 11-026 |  | PE | 13-015 | PR |  |  | 12-054 | ST |  |  |  |  |  |  |  |  |  | 1 |  |  |  | 12-021 |  |  |  |  |  |  |  |  |  |  |  |
| 2562645a | Install cable trays and hardware FY14 | 34d | 2013-09-03 A | 2013-11-20 | 2562645 FS-40d | 20% | 14d | 2013-10-01 | 2013-11-15 | 121d | 16d | 8/5 M-F w/JLAB Holidays ReBaseline | MECH TECH [47.95 h] | 2,268.99 | 1,687.13 | 2562645 | 0 | 453.7988 | CHUDAKOV | 1 | 1 | D |  | S | EUGENE C |  | 11-006 | 11-026 |  | PE | 13-015 | PR | 14-001 |  | 12-054 | ST |  |  |  |  |  |  |  |  |  | 1 |  |  |  | 12-021 |  |  |  |  |  |  |  |  |  |  |  |
| 2562685 | Fiducialize and survey equipment (2013) | 20d | 2013-09-03 A | 2013-09-23 A | 9-130M FS+228d | 100% |  | 2013-10-01 | 2013-10-28 |  |  | 8/5 M-F w/JLAB Holidays ReBaseline | MECH TECH [29.62 h]; MECH ENG [5.92 h]; SUPPLIES & MATERIALS | 2,293.25 | 1,786.85 | 2562685 | 0 | 2236.32555 | CHUDAKOV | 1 | 1 | D |  | S | EUGENE C |  | 11-006 | 11-026 |  | PE | 13-015 | PR |  |  |  | ST | EJ |  |  |  |  |  |  |  |  | 1 |  |  |  | 12-021 |  |  |  |  |  |  |  |  |  |  |  |
| 2562705 | Manufacturing Drawings of Chilled water system for Hall D | 12d | 2013-09-03 A | 2013-10-21 A | 9-130M FS+228d | 100% |  | 2013-10-01 | 2013-10-16 |  |  | 8/5 M-F w/JLAB Holidays ReBaseline | MECH ENG [68 h]; MECH DES [68 h] | 8,565.96 | 8,469.52 | 2562705 | 4067.3724 | 4233.3876 | CHUDAKOV | 1 | 1 | D |  | S | EUGENE C |  |  |  | 13-007 | PE | 13-015 | PR |  |  |  | ST |  |  |  |  |  |  |  |  |  |  |  |  |  |  |  |  |  |  |  |  |  |  |  |  |  |
| 2562730 | Install Upstream cable trays (FDC/CDC/SC) FY13 | 20d | 2013-09-03 A | 2013-11-13 | 2562225 FS-20d | 67% | 9d | 2013-10-01 | 2013-10-28 | 67d | 31d | 8/5 M-F w/JLAB Holidays ReBaseline | MECH TECH [88.28 h]; MECH ENG [6.62 h]; MECH DES [4.41 h] | 4,898 | 3,992.11 | 2562730 | 1580.68352288 | 1580.68352287 | CHUDAKOV | 1 | 1 | D |  | S | EUGENE C |  |  |  | 13-007 | PE | 13-015 | PR |  |  |  | ST |  |  |  |  |  |  |  |  |  |  |  |  |  |  |  |  |  |  |  |  |  |  |  |  |  |
| 2562730a | Install Upstream cable trays (FDC/CDC/SC) FY14 | 9d | 2013-09-03 A | 2013-11-13 | 2562730 FS-40d | 67% | 9d | 2013-10-01 | 2013-10-11 | 67d | 48d | 8/5 M-F w/JLAB Holidays ReBaseline | MECH TECH [39.72 h]; MECH ENG [2.98 h]; MECH DES [1.99 h] | 2,204.12 | 1,796.47 | 2562730 | 733.97218444 | 733.97218444 | CHUDAKOV | 1 | 1 | D |  | S | EUGENE C |  |  |  | 13-007 | PE | 13-015 | PR | 14-001 |  |  | ST |  |  |  |  |  |  |  |  |  |  |  |  |  |  |  |  |  |  |  |  |  |  |  |  |  |
| 2562785 | Materials for install 2013 (Previously Obligated) | 20d | 2013-09-03 A | 2013-09-30 A | 9-130M FS+228d | 100% |  | 2013-10-01 | 2013-10-28 |  |  | 8/5 M-F w/JLAB Holidays ReBaseline | PROCUREMENT<$50K 60 | 3,757 |  | 2562785 | 0 | 3757 | CHUDAKOV | 1 | 1 | D |  | E | EUGENE C |  |  |  | 13-007 |  | 13-015 | PR |  |  |  |  |  |  |  | 100 | 100 | 0 | 3757 | 375700 | 100 |  |  | PE | OB |  |  |  |  |  |  |  |  |  |  |  |  |
| 2562790 | Materials for install 2013 | 20d | 2013-09-03 A | 2013-09-30 A | 9-130M FS+228d | 100% |  | 2013-10-01 | 2013-10-28 |  |  | 8/5 M-F w/JLAB Holidays ReBaseline | PROCUREMENT<$50K 60 | 2,953 |  | 2562785 | 0 | 2953 | CHUDAKOV | 1 | 1 | D |  | E | EUGENE C |  |  |  | 13-007 |  | 13-015 | PR |  |  |  |  |  |  |  | 100 | 100 | 0 | 2953 | 295300 | 100 |  |  | PE | OB |  |  |  |  |  |  |  |  |  |  |  |  |
| 2562805 | Manufacturing Drawings of N2 purge system FY13 | 18d | 2013-09-03 A | 2013-11-14 | 9-130M FS+230d | 97% | 10d | 2013-10-01 | 2013-10-24 | 107d | 13d | 8/5 M-F w/JLAB Holidays ReBaseline | MECH ENG [56.47 h]; MECH DES [84.71 h] | 8,562.28 | 6,846.71 | 2562805 | 4480.460244 | 3567.773898 | CHUDAKOV | 1 | 1 | D |  | S | EUGENE C |  |  |  | 13-007 | PE | 13-015 | PR |  |  |  | ST |  |  |  |  |  |  |  |  |  |  |  |  |  |  |  |  |  |  |  |  |  |  |  |  |  |
| 2562805a | Manufacturing Drawings of N2 purge system FY14 | 33d | 2013-09-03 A | 2013-11-14 | 2562805 FS-40d | 97% | 10d | 2013-10-01 | 2013-11-14 | 107d | 13d | 8/5 M-F w/JLAB Holidays ReBaseline | MECH ENG [103.53 h]; MECH DES [155.29 h] | 15,696.92 | 12,551.82 | 2562805 | 8476.3342944 | 6749.6736048 | CHUDAKOV | 1 | 1 | D |  | S | EUGENE C |  |  |  | 13-007 | PE | 13-015 | PR | 14-001 |  |  | ST |  |  |  |  |  |  |  |  |  |  |  |  |  |  |  |  |  |  |  |  |  |  |  |  |  |
| 2562830 | Install BCAL cooling manifold FY13 | 20d | 2013-09-03 A | 2013-10-21 A | 25221320 FS-23d | 100% |  | 2013-10-01 | 2013-10-28 |  |  | 8/5 M-F w/JLAB Holidays ReBaseline | MECH TECH [74.41 h]; MECH ENG [3.72 h]; MECH DES [3.72 h] | 3,989.71 | 3,950.61 | 2562830 | 3557.23226428 | 309.32454472 | CHUDAKOV | 1 | 1 | D |  | S | EUGENE C |  |  |  | 13-007 | PE | 13-015 | PR |  |  |  | ST |  |  |  |  |  |  |  |  |  |  |  |  |  |  |  |  |  |  |  |  |  |  |  |  |  |
| 2562830a | Install BCAL cooling manifold FY14 | 20d | 2013-09-03 A | 2013-10-21 A | 2562830 FS-20d | 100% |  | 2013-10-29 | 2013-11-25 |  |  | 8/5 M-F w/JLAB Holidays ReBaseline | MECH TECH [74.41 h]; MECH ENG [3.72 h]; MECH DES [3.72 h] | 3,989.71 | 3,950.61 | 2562830 | 3670.52754752 | 319.17630848 | CHUDAKOV | 1 | 1 | D |  | S | EUGENE C |  |  |  | 13-007 | PE | 13-015 | PR | 14-001 |  |  | ST |  |  |  |  |  |  |  |  |  |  |  |  |  |  |  |  |  |  |  |  |  |  |  |  |  |
| 2562835 | Install PS shielding | 31d | 2013-09-03 A | 2013-11-15 | 9-140M | 55% | 11d | 2013-10-04 | 2013-11-15 | 213d |  | 8/5 M-F w/JLAB Holidays ReBaseline | MECH TECH [96 h]; MECH DES [4 h]; MECH ENG [4 h] | 5,046.6 | 3,960.9 | 2562835 | 50.46599999 | 2725.164 | CHUDAKOV | 1 | 1 | D |  | S | EUGENE C |  |  |  | 13-007 | PE | 13-015 | PR | 14-001 |  |  | ST |  |  |  |  |  |  |  |  |  |  |  |  |  |  |  |  |  |  |  |  |  |  |  |  |  |
| 2562895 | Preparing OSP ESAD documentation Rediness Review for April 14 Beam Run FY13 | 20d | 2013-09-03 A | 2014-05-13 | 9-130M FS+228d | 4% | 127d | 2013-10-01 | 2013-10-28 | 97d | 33d | 8/5 M-F w/JLAB Holidays ReBaseline | MECH TECH [8.75 h]; MECH ENG [43.77 h]; SR STAFF [17.51 h]; SCIENTIST [51.77 h]; MECH DES [26.26 h]; ELEC ENG [13.13 h]; SUPPLIES & MATERIALS | 12,287.36 | 2,995.11 | 2562895 | 6.442 | 476.6419952 | CHUDAKOV | 1 | 1 | D |  | S | EUGENE C |  |  |  | 13-007 | PE | 13-015 | PR |  |  |  | ST | PE |  |  |  |  |  |  |  |  |  |  |  |  |  |  |  |  |  |  |  |  |  |  |  |  |
| 2562895a | Preparing OSP ESAD documentation Rediness Review for April 14 Beam Run FY14 | 150d | 2013-09-03 A | 2014-05-13 | 2562895 FS-160d | 4% | 127d | 2013-10-01 | 2014-05-13 | 97d |  | 8/5 M-F w/JLAB Holidays ReBaseline | MECH TECH [65.65 h]; MECH ENG [328.23 h]; SR STAFF [131.29 h]; SCIENTIST [388.23 h]; MECH DES [196.94 h]; ELEC ENG [98.47 h]; SUPPLIES & MATERIALS | 92,218.41 | 22,462.76 | 2562895 | -6.648 | 3688.73681836 | CHUDAKOV | 1 | 1 | D |  | S | EUGENE C |  |  |  | 13-007 | PE | 13-015 | PR | 14-001 |  |  | ST | PE |  |  |  |  |  |  |  |  |  |  |  |  |  |  |  |  |  |  |  |  |  |  |  |  |
| 2562098 | Install Tagger Quad Stand & Magnet (Installtn) | 64d | 2013-09-09 A | 2014-01-30 | 2562045 FS-15d, 2562045a FS-15d | 9% | 54d | 2013-10-18 | 2014-01-30 | 170d | 41d | 8/5 M-F w/JLAB Holidays ReBaseline | MECH TECH [168 h]; ELEC TECH [16 h]; MECH ENG [24 h] | 10,493.68 | 4,344.85 | 2562098 | 0 | 944.4312 | CHUDAKOV | 1 | 1 | D | 07-024 | S | EUGENE C | 09-014 | 11-006 | 11-026 | 13-007 | PE | 13-015 | PR | 14-001 |  | 12-054 | ST |  |  |  |  |  |  |  |  |  |  |  |  |  | 12-021F | 11-004 |  |  |  |  |  |  |  |  |  |  |
| 2562710 | Procure Chilled water components | 33d | 2013-09-09 A | 2013-11-18 | 2562705 FS-15d, 9-140M | 90% | 12d | 2013-10-17 | 2013-12-04 | 162d | 38d | 8/5 M-F w/JLAB Holidays ReBaseline | PROCUREMENT<$50K 60 | 10,112.62 |  | 2562710 | 7483.3388 | 1618.0192 | CHUDAKOV | 1 | 1 | D |  | D | EUGENE C |  |  |  | 13-007 |  | 13-015 | PR | 14-001 |  |  |  |  |  |  |  |  | 1011.262 | 9101.358 | 910135.8 | 100 |  |  | EJ | OB-2 |  |  |  |  |  |  |  |  |  |  |  |  |
| 2562715 | Install Chilled water sytem Hall D | 46d | 2013-09-09 A | 2014-01-09 | 2562710 FS-50d | 93% | 40d | 2013-11-07 | 2014-01-24 | 124d | 50d | 8/5 M-F w/JLAB Holidays ReBaseline | MECH TECH [288 h]; MECH ENG [8 h]; MECH DES [8 h] | 14,635.92 | 7,133.86 | 2562715 | 11562.3768 | 2049.0288 | CHUDAKOV | 1 | 1 | D |  | S | EUGENE C |  |  |  | 13-007 | PE | 13-015 | PR | 14-001 |  |  | ST |  |  |  |  |  |  |  |  |  |  |  |  |  |  |  |  |  |  |  |  |  |  |  |  |  |
| 2562061 | Field Map Tagging Magnet (Installtn) | 63d | 2013-09-16 A | 2014-01-09 | 25511095 FS-40d, 2562063 FS-32d, 2562845 FS-120d, 25511095a FS-40d, 2562045a FS-11d, 2562050 FS-13d, 2562045 FS-11d, 2562050a FS-13d, 2562440 FS-200d | 26% | 40d | 2013-10-29 | 2014-02-07 | 124d | 57d | 8/5 M-F w/JLAB Holidays ReBaseline | MECH TECH [188 h]; SCIENTIST [75.2 h]; MECH ENG [112.8 h] | 22,972.48 | 10,449.45 | 2562061 | 4824.21912 | 1148.6236 | CHUDAKOV | 1 | 1 | D | 07-024 | S | EUGENE C | 09-014 | 11-006 | 11-026 | 13-007 | PE | 13-015 | PR | 14-001 |  | 12-054 | ST |  |  |  |  |  |  |  |  |  |  |  |  |  |  |  | 11-030 |  |  |  |  |  |  |  |  |  |
| 2562393 | Install/test gas systems | 52d | 2013-09-16 A | 2013-12-13 | 2562392 FS-106d, 9-140M, 2562392a FS-106d | 31% | 29d | 2013-11-01 | 2014-01-28 | 68d | 45d | 8/5 M-F w/JLAB Holidays ReBaseline | MECH DES [63.36 h]; SCIENTIST [119.68 h]; MECH ENG [63.36 h]; MECH TECH [1020.8 h]; SUPPLIES & MATERIALS | 65,828.1 | 34,880.39 | 2562393 | 8557.652688 | 11849.057568 | CHUDAKOV | 1 | 1 | D | 07-024 | S | EUGENE C | 09-014 | 11-006 | 11-026 | 13-007 | EJ | 13-015 | PR | 14-001 |  | 12-054 | ST | EJ |  |  |  |  |  |  |  |  |  |  |  |  | 12-021 |  |  | 10-042 |  |  |  |  |  |  |  |  |
| 2562006LOE | FY14 Work Cordinator (Installtn) | 245d | 2013-10-01 A | 2014-09-26 | 2562005LOE | 9% | 222d | 2013-11-01 | 2014-10-29 | 252d |  | 8/5 M-F w/JLAB Holidays ReBaseline | MECH ENG [1760 h] | 131,419.2 | 12,337.31 | 2562006LOE | 12340.26288 |  | CHUDAKOV | 1 | 1 | D | 07-024 | E | EUGENE C |  |  | 11-026 |  | PE | 13-015 | PR | 14-001 |  |  |  |  | 90.61224489 | 9.3877551 | 100 | 100 |  |  |  |  |  |  |  |  |  |  |  |  | 09-027 | 09-027 |  |  |  |  |  |  |
| 2562014E | FY14 Travel (Installtn) | 247d | 2013-10-01 A | 2014-09-30 | 2562000, 2562013E | 9% | 224d | 2013-11-01 | 2014-10-31 | 250d |  | 8/5 M-F w/JLAB Holidays ReBaseline | TRAVEL | 1,031.9 |  | 2562014E | 96.06989 |  | CHUDAKOV | 1 | 1 | D | 07-024 | E | EUGENE C |  |  | 11-026 |  |  | 13-015 | PR | 14-001 |  |  |  | PE | 90.6882591 | 9.31174089 | 100 | 100 |  |  |  |  |  |  |  |  |  |  |  |  |  |  |  |  |  |  |  |  |
| 2562231 | Manufacturing Drawings of BCAL Lateral support | 20d | 2013-10-01 A | 2013-12-02 | 9-140M FS+2d | 71% | 20d | 2013-11-01 | 2013-12-02 | 181d | 0d | 8/5 M-F w/JLAB Holidays ReBaseline | MECH DES [52.8 h]; MECH ENG [35.2 h] | 5,337.02 | 2,854.69 | 2562231 | 3789.28704 |  | CHUDAKOV | 1 | 1 | D |  | S | EUGENE C |  |  |  | 13-007 | PE | 13-015 | PR | 14-001 |  |  | ST |  |  |  |  |  |  |  |  |  |  |  |  |  |  |  |  |  |  |  |  |  |  |  |  |  |
| 2562233 | Install BCAL lateral support | 24d | 2013-10-01 A | 2014-01-29 | 2562232 FS-60d | 24% | 53d | 2014-01-27 | 2014-02-27 | 160d | 9d | 8/5 M-F w/JLAB Holidays ReBaseline | MECH TECH [80 h]; SUPPLIES & MATERIALS; MECH ENG [4 h] | 4,393.85 | 1,236.03 | 2562233 | 1054.524 |  | CHUDAKOV | 1 | 1 | D |  | S | EUGENE C |  |  |  | 13-007 | PE | 13-015 | PR | 14-001 |  |  | ST | EJ |  |  |  |  |  |  |  |  |  |  |  |  |  |  |  |  |  |  |  |  |  |  |  |  |
| 2562245 | Racks - Install Hall Lower Level Upstream (U1) | 8d | 2013-10-01 A | 2013-10-21 A | 2562225 FS-4d | 100% |  | 2013-11-01 | 2013-11-12 |  |  | 8/5 M-F w/JLAB Holidays ReBaseline | ELEC TECH [2 h]; MECH TECH [18 h] | 945.74 | 945.74 | 2562245 | 945.74 |  | CHUDAKOV | 1 | 1 | D | 07-024 | S | EUGENE C | 09-014 | 11-006 | 11-026 | 13-007F | PE | 13-015 | PR | 14-001 |  | 12-054 | ST |  |  |  |  |  |  |  |  |  | 1 |  |  |  |  |  |  |  |  |  | 11-044 |  |  |  |  |  |
| 2562250 | Install Pwr to Racks Upstream Platform (Installtn) - Procurement | 57d | 2013-10-01 A | 2013-11-26 | 2562245 FS-24d | 10% | 18d | 2013-11-01 | 2014-02-04 | 162d | 51d | 8/5 M-F w/JLAB Holidays ReBaseline | ELEC TECH; PROCUREMENT>$50K 69 NO ESCALATION FY14 | 20,645.33 |  | 2562250 | 2064.533 |  | CHUDAKOV | 1 | 1 | D | 07-024 | S | EUGENE C | 09-014 | 11-006 | 11-026 | 13-007F | PE | 13-015 | PR |  | APP | 12-054 | ST |  |  |  |  |  | 18580.797 | 2064.533 | 206453.3 | 100 | 1 |  | EJ | OB-2 |  |  |  |  |  |  | 11-044 |  |  |  |  |  |
| 2562250a | Install Pwr to Racks Upstream Platform (Installtn) - Labor FY13 | 20d | 2013-10-01 A | 2013-11-26 | 2562245 FS-24d | 10% | 18d | 2013-11-01 | 2013-12-02 | 174d | 12d | 8/5 M-F w/JLAB Holidays ReBaseline | ELEC TECH [101.05 h] | 4,748.34 | 2,663.7 | 2562250 | 460.1817 |  | CHUDAKOV | 1 | 1 | D | 07-024 | S | EUGENE C | 09-014 | 11-006 | 11-026 | 13-007F | PE | 13-015 | PR |  | APP | 12-054 | ST |  |  |  |  |  |  |  |  |  | 1 |  | EJ |  |  |  |  |  |  |  | 11-044 |  |  |  |  |  |
| 2562250b | Install Pwr to Racks Upstream Platform (Installtn) - Labor FY14 | 37d | 2013-10-01 A | 2013-11-26 | 2562250a FS-30d | 10% | 18d | 2013-12-03 | 2014-02-04 | 162d | 51d | 8/5 M-F w/JLAB Holidays ReBaseline | ELEC TECH [186.95 h] | 8,784.78 | 4,928.05 | 2562250 | 878.47805 |  | CHUDAKOV | 1 | 1 | D | 07-024 | S | EUGENE C | 09-014 | 11-006 | 11-026 | 13-007F | PE | 13-015 | PR | 14-001 | APP | 12-054 | ST |  |  |  |  |  |  |  |  |  | 1 |  | EJ |  |  |  |  |  |  |  | 11-044 |  |  |  |  |  |
| 2562275 | Cables - Install on Trays Detector to Racks BCAL FY13 | 2d | 2013-10-01 A | 2013-10-21 A | 2547180 FS-2d, 2547175 FS-2d | 100% |  | 2013-11-01 | 2013-11-04 |  |  | 8/5 M-F w/JLAB Holidays ReBaseline | SCIENTIST; ELEC TECH [20 h]; MECH TECH [20 h] | 1,886.2 | 1,886.2 | 2562275 | 1828 |  | CHUDAKOV | 1 | 1 | D | 07-024 | U | EUGENE C | 09-014 | 11-006 | 11-026 | 13-007 | PE | 13-015 | PR |  |  | 12-054 |  |  |  |  |  |  |  |  |  |  | 1 |  |  |  | 12-021 |  |  | 10-042 |  |  |  |  |  |  |  |  |
| 2562275a | Cables - Route and Connect on Detector BCAL | 28d | 2013-10-01 A | 2013-12-06 | 2562275 FS-3d, 2562275d FS-3d | 80% | 24d | 2013-12-04 | 2014-01-23 | 85d | 11d | 8/5 M-F w/JLAB Holidays ReBaseline | SCIENTIST; ELEC TECH [160 h]; MECH TECH [160 h] | 15,089.6 | 7,384.28 | 2562275a | 12071.68 |  | CHUDAKOV | 1 | 1 | D | 07-024 | U | EUGENE C | 09-014 | 11-006 | 11-026 | 13-007 | PE | 13-015 | PR | 14-001 |  | 12-054 |  |  |  |  |  |  |  |  |  |  |  |  |  |  | 12-021 |  |  |  |  |  |  |  |  |  |  |  |
| 2562275b | Cables - Route on Racks BCAL | 23d | 2013-10-01 A | 2013-12-20 | 2562275a FS-35d | 60% | 34d | 2014-01-06 | 2014-02-06 | 74d | 11d | 8/5 M-F w/JLAB Holidays ReBaseline | SCIENTIST; ELEC TECH [80 h]; MECH TECH [40 h] | 5,652 | 2,280.63 | 2562275b | 3391.2 |  | CHUDAKOV | 1 | 1 | D | 07-024 | U | EUGENE C | 09-014 | 11-006 | 11-026 | 13-007 | PE | 13-015 | PR | 14-001 |  | 12-054 |  |  |  |  |  |  |  |  |  |  |  |  |  |  | 12-021 |  |  |  |  |  |  |  |  |  |  |  |
| 2562275c | Cables - Connect to Crate Electronics BCAL | 18d | 2013-10-01 A | 2013-12-20 | 2562275b FS-45d | 50% | 34d | 2014-01-13 | 2014-02-06 | 63d | 0d | 8/5 M-F w/JLAB Holidays ReBaseline | ELEC TECH [120 h]; ELEC ENG [40 h] | 8,644 | 3,487.93 | 2562275c | 4322 |  | CHUDAKOV | 1 | 1 | D | 07-024 | U | EUGENE C | 09-014 | 11-006 | 11-026 | 13-007 | PE | 13-015 | PR | 14-001 |  | 12-054 |  |  |  |  |  |  |  |  |  |  |  |  |  |  | 12-021 |  |  |  |  |  |  |  |  |  |  |  |
| 2562275d | Cables - Install on Trays Detector to Racks BCAL FY14 | 22d | 2013-10-01 A | 2013-10-21 A | 2562275 | 100% |  | 2013-11-05 | 2013-12-06 |  |  | 8/5 M-F w/JLAB Holidays ReBaseline | SCIENTIST; ELEC TECH [220 h]; MECH TECH [220 h] | 20,748.2 | 20,748.2 | 2562275 | 20748.2 |  | CHUDAKOV | 1 | 1 | D | 07-024 | U | EUGENE C | 09-014 | 11-006 | 11-026 | 13-007 | PE | 13-015 | PR | 14-001 |  | 12-054 |  |  |  |  |  |  |  |  |  |  | 1 |  |  |  | 12-021 |  |  | 10-042 |  |  |  |  |  |  |  |  |
| 2562335 | Install Pwr to Racks Platform #2 (Installtn) - Procurement | 34d | 2013-10-01 A | 2013-12-20 | 2562330 FS+2d | 70% | 34d | 2013-12-06 | 2014-02-04 | 190d |  | 8/5 M-F w/JLAB Holidays ReBaseline | ELEC ENG; MECH TECH; PROCUREMENT>$50K 69 NO ESCALATION FY14 | 29,338.1 |  | 2562335 | 20536.67 |  | CHUDAKOV | 1 | 1 | D |  | S | EUGENE C | 09-014 | 11-006 | 11-026 |  | PE | 13-015 | PR |  | APP | 12-054 | ST |  |  |  |  |  | 8801.43 | 20536.67 | 2053667 | 100 |  |  | EJ | OB-2 |  |  |  |  |  |  | 11-044 |  |  |  |  |  |
| 2562335a | Install Pwr to Racks Platform #2 (Installtn) - Labor FY13 | 20d | 2013-10-01 A | 2013-12-20 | 2562330 FS+2d | 70% | 34d | 2013-11-01 | 2013-12-02 | 196d | 6d | 8/5 M-F w/JLAB Holidays ReBaseline | ELEC ENG [1.68 h]; MECH TECH [42.08 h] | 2,117.53 | 854.44 | 2562335 | 1436.5347675 |  | CHUDAKOV | 1 | 1 | D |  | S | EUGENE C | 09-014 | 11-006 | 11-026 |  | PE | 13-015 | PR |  | APP | 12-054 | ST |  |  |  |  |  |  |  |  |  |  |  | EJ |  |  |  |  |  |  |  | 11-044 |  |  |  |  |  |
| 2562335b | Install Pwr to Racks Platform #2 (Installtn) - Labor FY14 | 57d | 2013-10-01 A | 2013-12-20 | 2562335a FS-40d | 70% | 34d | 2013-12-03 | 2014-03-04 | 190d |  | 8/5 M-F w/JLAB Holidays ReBaseline | ELEC ENG [4.8 h]; MECH TECH [119.92 h] | 6,035.15 | 2,435.24 | 2562335 | 4224.6069803 |  | CHUDAKOV | 1 | 1 | D |  | S | EUGENE C | 09-014 | 11-006 | 11-026 |  | PE | 13-015 | PR | 14-001 | APP | 12-054 | ST |  |  |  |  |  |  |  |  |  |  |  | EJ |  |  |  |  |  |  |  | 11-044 |  |  |  |  |  |
| 2562360 | Install FDC on Platform (Installtn) | 6d | 2013-10-01 A | 2013-10-21 A | 2561145 FS-10d, 2561145a FS-10d, 2561140 FS-2d | 100% |  | 2013-11-01 | 2013-11-08 |  |  | 8/5 M-F w/JLAB Holidays ReBaseline | MECH ENG [24 h]; PROCUREMENT<$50K 60; MECH TECH [120 h] | 11,208 | 7,470.48 | 2562360 | 11208 |  | CHUDAKOV | 1 | 1 | D | 07-024 | H | EUGENE C | 09-014 | 11-006 | 11-026 | 13-007 | EJ | 13-015 | PR | 14-001 | APP | 12-054 |  |  |  |  |  |  | 0 | 3737.52 | 373752 | 100 |  |  | EJ | OB-2 |  |  |  | 10-042 |  |  |  |  |  |  |  |  |
| 2562405 | Install Pwr to FCAL/TOF Racks (Installtn) | 75d | 2013-10-01 A | 2013-12-13 | 9-130M FS+228d | 82% | 29d | 2013-11-01 | 2014-02-28 | 23d | 3d | 8/5 M-F w/JLAB Holidays ReBaseline | PROCUREMENT<$50K 60 NO ESCALATION FY14 | 19,558.72 |  | 2562405 | 16038.1504 |  | CHUDAKOV | 1 | 1 | D | 07-024 | S | EUGENE C | 09-014 | 11-006 | 11-026 | 13-007F |  | 13-015 | PR |  | APP | 12-054 | ST |  |  |  |  |  | 3520.5696 | 16038.1504 | 1603815.04 | 100 |  |  | PE | OB-2 |  |  |  |  |  |  | 11-044 |  |  |  |  |  |
| 2562445a | Engineering Support for Installation 2014 (Installtn) | 228d | 2013-10-01 A | 2014-09-03 | 2562445 | 10% | 205d | 2013-11-01 | 2014-10-06 | 19d |  | 8/5 M-F w/JLAB Holidays ReBaseline | MECH DES [845.81 h]; MECH ENG [698.71 h] | 95,562.76 | 9,640.1 | 2562445 | 9556.2762095 |  | CHUDAKOV | 1 | 1 | D | 07-024 | E | EUGENE C | 09-014 | 11-006 | 11-026 |  | PE | 13-015 | PR | 14-001 |  |  |  |  | 89.9122807 | 10.08771929 | 100 | 100 |  |  |  |  |  |  |  |  |  |  |  |  | 09-027 | 09-027 |  | 2 |  |  |  |  |
| 2562615LOE | Electrical power engineer support 2014 | 247d | 2013-10-01 A | 2014-09-30 | 2562610LOE | 9% | 224d | 2013-11-01 | 2014-10-31 | 245d |  | 8/5 M-F w/JLAB Holidays ReBaseline | ELEC ENG [880 h] | 66,114.4 | 6,156.4 | 2562615LOE | 6155.25064 |  | CHUDAKOV | 1 | 1 | D |  | E | EUGENE C |  | 11-006 | 11-026 | 13-007 | PE | 13-015 | PR | 14-001 |  |  |  |  | 90.6882591 | 9.31174089 | 100 | 100 |  |  |  |  | 1 |  |  |  | 12-021 |  |  |  |  |  |  |  |  |  |  |  |
| 2562690 | Manufacturing Drawings of cooling system for FCAL dark room FY13 | 20d | 2013-10-01 A | 2013-12-02 | 9-130M FS+228d | 70% | 20d | 2013-11-01 | 2013-12-02 | 193d | 0d | 8/5 M-F w/JLAB Holidays ReBaseline | MECH ENG [4 h]; MECH DES [8.89 h] | 754.75 | 403.7 | 2562690 | 511.9587998 |  | CHUDAKOV | 1 | 1 | D |  | S | EUGENE C |  |  |  | 13-007 | PE | 13-015 | PR |  |  |  | ST |  |  |  |  |  |  |  |  |  |  |  |  |  |  |  |  |  |  |  |  |  |  |  |  |  |
| 2562690a | Manufacturing Drawings of cooling system for FCAL dark room FY14 | 16d | 2013-10-01 A | 2013-12-02 | 2562690 FS-20d | 70% | 20d | 2013-12-03 | 2014-01-03 | 193d | 10d | 8/5 M-F w/JLAB Holidays ReBaseline | MECH ENG [3.2 h]; MECH DES [7.11 h] | 603.68 | 322.89 | 2562690 | 422.5752566 |  | CHUDAKOV | 1 | 1 | D |  | S | EUGENE C |  |  |  | 13-007 | PE | 13-015 | PR | 14-001 |  |  | ST |  |  |  |  |  |  |  |  |  |  |  |  |  |  |  |  |  |  |  |  |  |  |  |  |  |
| 2562740 | Manufacturing Drawings of dry air cooling upstream racks/drift chambers | 30d | 2013-10-01 A | 2013-11-14 | 9-140M FS+3d | 18% | 10d | 2013-11-01 | 2013-12-16 | 143d | 8d | 8/5 M-F w/JLAB Holidays ReBaseline | MECH ENG [200 h]; MECH DES [188 h] | 24,578.4 | 17,130.4 | 2562740 | 4424.112 |  | CHUDAKOV | 1 | 1 | D |  | S | EUGENE C |  |  |  | 13-007 | PE | 13-015 | PR | 14-001 |  |  | ST |  |  |  |  |  |  |  |  |  |  |  |  |  |  |  |  |  |  |  |  |  |  |  |  |  |
| 2562865 | Procure lighting fixture under US platform | 24d | 2013-10-01 A | 2013-10-21 A | 9-130M FS+228d | 100% |  | 2013-11-01 | 2013-12-06 |  |  | 8/5 M-F w/JLAB Holidays ReBaseline | PROCUREMENT<$50K 60 NO ESCALATION FY14 | 550 |  | 2562865 | 550 |  | CHUDAKOV | 1 | 1 | D |  | D | EUGENE C |  |  |  | 13-007 |  | 13-015 | PR |  |  |  |  |  |  |  |  |  | 0 | 550 | 55000 | 100 |  |  | PE | OB-2 |  |  |  |  |  |  |  |  |  |  |  |  |
| 2562890 | Detector Readout Electronics Support Documentation and OSP | 248d | 2013-10-01 A | 2014-10-01 | 9-140M | 8% | 225d | 2013-11-01 | 2014-11-03 | 10d | 0d | 8/5 M-F w/JLAB Holidays ReBaseline | ELEC ENG [640 h]; ELEC TECH [640 h]; SR STAFF [520 h] | 140,723.2 | 13,050.94 | 2562890 | 11257.856 |  | CHUDAKOV | 1 | 1 | D |  | S | EUGENE C |  |  |  | 13-007 | PE | 13-015 | PR | 14-001 |  |  | ST |  |  |  |  |  |  |  |  |  |  |  |  |  |  |  |  |  |  |  |  |  |  |  |  |  |
| 2562636 | Manufacture Drawing Inst Air Sys | 25d | 2013-10-07 A | 2014-01-02 | 2562805a FS-40d, 2562805 FS-40d | 78% | 35d | 2013-12-20 | 2014-02-05 | 159d | 0d | 8/5 M-F w/JLAB Holidays ReBaseline | MECH ENG [160 h]; MECH DES [240 h] | 24,259.2 | 8,535.64 | 2562636 | 18922.176 |  | CHUDAKOV | 1 | 1 | D |  | S | EUGENE C |  | 11-006 | 11-026 |  | PE | 13-015 | PR | 14-001 |  |  | ST |  |  |  |  |  |  |  |  |  | 1 |  |  |  | 12-021 |  |  |  |  |  |  |  |  |  |  |  |
| 2562540 | Crates - Loaded (VME64x VXS HV LV) Install Hall BCAL | 10d | 2013-10-10 A | 2013-11-14 | 2562535 FS-80d, 2548025 FS-25d, 2548025a FS-25d | 60% | 10d | 2013-12-10 | 2014-01-02 | 124d | 0d | 8/5 M-F w/JLAB Holidays ReBaseline | ELEC TECH [320 h] | 15,036.8 | 9,253.42 | 2562540 | 9022.08 |  | CHUDAKOV | 1 | 1 | D |  | U | EUGENE C |  | 11-006 | 11-026 |  | PE | 13-015 | PR | 14-001 |  | 12-054 |  |  |  |  |  |  |  |  |  |  | 1 |  |  |  | 12-021 |  |  |  |  |  |  |  |  |  |  |  |
| 2562365 | Alignment of FDC (Installtn) | 7d | 2013-10-11 A | 2013-11-11 | 2562360 | 50% | 7d | 2013-11-11 | 2013-11-19 | 21d | 5d | 8/5 M-F w/JLAB Holidays ReBaseline | MECH ENG [40 h]; MECH TECH [120 h] | 8,665.2 | 5,908.09 | 2562365 | 4332.6 |  | CHUDAKOV | 1 | 1 | D | 07-024 | H | EUGENE C | 09-014 | 11-006 | 11-026 | 13-007 | EJ | 13-015 | PR | 14-001 |  | 12-054 |  |  |  |  |  |  |  |  |  |  |  |  |  |  |  |  |  | 10-042 |  |  |  |  |  |  |  |  |
| 2562535 | Crates - Loaded (VME64x VXS HV LV) Install Hall FDC | 50d | 2013-10-12 A | 2014-01-24 | 2548025 FS-64d, 2548020 FS-46d, 2548020a FS-100d, 2548025a FS-64d, 9-140M | 10% | 50d | 2013-12-12 | 2014-03-04 | 114d | 30d | 8/5 M-F w/JLAB Holidays ReBaseline | ELEC TECH [320 h] | 15,036.8 | 3,289.3 | 2562535 | 1503.68 |  | CHUDAKOV | 1 | 1 | D |  | U | EUGENE C |  | 11-006 | 11-026 |  | PE | 13-015 | PR | 14-001 |  | 12-054 |  |  |  |  |  |  |  |  |  |  | 1 |  |  |  | 12-021 |  |  |  |  |  |  |  |  |  |  |  |
| 2562530 | Crates - Loaded (VME64x VXS HV LV) Install Hall CDC | 26d | 2013-10-14 A | 2013-12-10 | 2548020a FS-100d, 2548020 FS-20d | 10% | 26d | 2014-02-27 | 2014-04-03 | 160d | 49d | 8/5 M-F w/JLAB Holidays ReBaseline | ELEC TECH [160 h] | 7,518.4 | 2,631.44 | 2562530 | 751.84 |  | CHUDAKOV | 1 | 1 | D |  | U | EUGENE C |  | 11-006 | 11-026 |  | PE | 13-015 | PR | 14-001 |  | 12-054 |  |  |  |  |  |  |  |  |  |  | 1 |  |  |  | 12-021 |  |  |  |  |  |  |  |  |  |  |  |
| 2562700 | Install Cooling system for FCAL dark room | 21d | 2013-10-14 A | 2013-12-03 | 9-140M FS+13d, 2562690 FS-30d, 2562690a FS-30d | 50% | 21d | 2013-12-03 | 2014-01-10 | 183d | 0d | 8/5 M-F w/JLAB Holidays ReBaseline | MECH TECH [120 h]; MECH ENG [8 h] | 6,275.76 | 2,510.3 | 2562700 | 3137.88 |  | CHUDAKOV | 1 | 1 | D |  | S | EUGENE C |  |  |  | 13-007 | EJ | 13-015 | PR | 14-001 |  |  | ST |  |  |  |  |  |  |  |  |  |  |  |  |  |  |  |  |  |  |  |  |  |  |  |  |  |
| 2562810 | Procure N2 purge system | 54d | 2013-10-15 A | 2014-01-10 | 2562805a FS-23d, 2562805 FS-23d | 60% | 41d | 2013-11-15 | 2014-02-13 | 94d | 0d | 8/5 M-F w/JLAB Holidays ReBaseline | PROCUREMENT<$50K 60 | 5,572.26 |  | 2562810 | 3343.356 |  | CHUDAKOV | 1 | 1 | D |  | D | EUGENE C |  |  |  | 13-007 |  | 13-015 | PR | 14-001 |  |  |  |  |  |  |  |  | 2228.904 | 3343.356 | 334335.6 | 100 |  |  | EJ | OB-2 |  |  |  |  |  |  |  |  |  |  |  |  |
| 2562246 | Racks - Install Hall Lower Level Upstream South (US1) | 24d | 2013-10-21 A | 2013-11-21 | 2562245 FS+6d, 2562225 FS-19d | 60% | 15d | 2013-11-21 | 2014-01-07 | 199d | 47d | 8/5 M-F w/JLAB Holidays ReBaseline | ELEC TECH [40 h]; MECH TECH [36 h] | 3,583.12 | 1,343.67 | 2562246 | 2149.872 |  | CHUDAKOV | 1 | 1 | D | 07-024 | S | EUGENE C | 09-014 | 11-006 | 11-026 | 13-007F | PE | 13-015 | PR | 14-001 |  | 12-054 | ST |  |  |  |  |  |  |  |  |  | 1 |  |  |  |  |  |  |  |  |  | 11-044 |  |  |  |  |  |
| 2562085 | Racks - Install Tagger FY13 | 20d | 2013-11-01 | 2013-12-02 | 9-130M FS+228d |  |  |  |  | 126d | 0d | 8/5 M-F w/JLAB Holidays ReBaseline | ELEC TECH [0.83 h]; SUPPLIES & MATERIALS; MECH TECH [7.45 h] | 412.23 |  | 2562085 | 0 |  | CHUDAKOV | 1 | 1 | D | 07-024 | S | EUGENE C | 09-014 | 11-006 | 11-026 | 13-007F | PE | 13-015 | PR |  |  | 12-054 | ST | EJ |  |  |  |  |  |  |  |  |  |  |  |  |  |  |  |  |  |  | 11-044 |  |  |  |  |  |
| 2562099 | Cables - Install on Trays Detector to Racks Pair Spectrometer | 14d | 2013-11-01 | 2013-11-20 | 9-130M FS+228d |  |  |  |  | 172d | 20d | 8/5 M-F w/JLAB Holidays ReBaseline | SCIENTIST; ELEC TECH [80 h] | 3,759.2 |  | 2562099 | 0 |  | CHUDAKOV | 1 | 1 | D | 07-024 | U | EUGENE C | 09-014 | 11-006 | 11-026 | 13-007 | PE | 13-015 | PR |  |  |  |  |  |  |  |  |  |  |  |  |  |  |  |  |  | 12-021 |  |  |  |  |  |  |  |  |  |  |  |
| 2562181 | Install Photon BL Colli. Cave (Installtn) - Procurement | 77d | 2013-11-01 | 2014-03-04 | 2553055 FS-130d, 2553057 FS-175d, 2553057a FS-175d |  |  |  |  | 147d |  | 8/5 M-F w/JLAB Holidays ReBaseline | MECH TECH; SUPPLIES & MATERIALS; MECH ENG; PROCUREMENT<$50K 60 NO ESCALATION FY14 | 1,750.63 |  | 2562181 | 0 |  | CHUDAKOV | 1 | 1 | D | 07-024 | S | EUGENE C | 09-014 | 11-006 | 11-026 | 13-007 | PE | 13-015 | PR |  | APP | 12-054 | ST | EJ |  |  |  |  | 1750.63 | 0 | 0 | 100 |  |  | PE |  | 12-021 |  |  |  |  |  |  |  |  |  |  |  |
| 2562181a | Install Photon BL Colli. Cave (Installtn) - Labor/Expenses FY13 | 20d | 2013-11-01 | 2013-12-02 | 2553055 FS-130d, 2553057 FS-175d, 2553057a FS-175d |  |  |  |  | 147d | 0d | 8/5 M-F w/JLAB Holidays ReBaseline | MECH TECH [18.08 h]; SUPPLIES & MATERIALS; MECH ENG [1.81 h] | 1,020.78 |  | 2562181 | 0 |  | CHUDAKOV | 1 | 1 | D | 07-024 | S | EUGENE C | 09-014 | 11-006 | 11-026 | 13-007 | PE | 13-015 | PR |  | APP | 12-054 | ST | EJ |  |  |  |  |  |  |  |  |  |  | PE |  | 12-021 |  |  |  |  |  |  |  |  |  |  |  |
| 2562214 | Fab field map fixture for PS magnet | 49d | 2013-11-01 | 2014-01-23 | 9-140M FS+8d |  |  |  |  | 143d | 0d | 8/5 M-F w/JLAB Holidays ReBaseline | PROCUREMENT<$50K 60 | 6,593.84 |  | 2562214 | 0 |  | CHUDAKOV | 1 | 1 | D |  | D | EUGENE C |  |  |  | 13-007 |  | 13-015 | PR | 14-001 | APP |  |  |  |  |  |  |  | 6593.84 | 0 | 0 | 100 | 1 |  | PE |  |  |  |  |  |  |  |  |  |  |  |  |  |
| 2562355 | Install Supprt Electrnc's Platform #2 (Installtn) - Procurement | 25d | 2013-11-01 | 2013-12-09 | 9-130M FS+228d |  |  |  |  | 199d |  | 8/5 M-F w/JLAB Holidays ReBaseline | MECH TECH; PROCUREMENT<$50K 60 NO ESCALATION FY14 | 8,451.3 |  | 2562355 | 0 |  | CHUDAKOV | 1 | 1 | D | 07-024 | U | EUGENE C |  | 11-006 | 11-026 |  | EJ | 13-015 | PR |  | APP | 12-054 |  |  |  |  |  |  | 8451.3 | 0 | 0 | 100 |  |  | EJ |  | 12-021 |  |  |  |  |  |  |  | 07-027 | 09-012 | 09-045 | 11-049 |

Notes:
- 2562480: Steps: Check LED bias settings (done); Procure pulsing system; Program pulsing system; Setup pulsing system
- 2562480a: Steps: Check LED bias settings (done); Procure pulsing system; Program pulsing system; Setup pulsing system
- 2562640: Steps: Procure cable trays for FCAL/TOF and north wall (done); Procure box duct for signal cable (done); Procure mounting hardware (done)
- 2562645: Steps: install cable trays on top of racks (done); install cable trays between solenoid platform and north wall
- 2562645a: Steps: install cable trays on top of racks (done); install cable trays between solenoid platform and north wall
- 2562685: Steps: Fiducialize and survey equipment (2013) (done)
- 2562705: Steps: Make Drawings (done); Check Drawings (done); Release drawing package (done); Issue procurment (done)
- 2562730: Steps: attach support underneath platform (done); install cable trays on top of racks/PS shield wall (done); install cable trays under platform
- 2562730a: Steps: attach support underneath platform (done); install cable trays on top of racks/PS shield wall (done); install cable trays under platform
- 2562805: Steps: Eng concept/develop requirements (done); 3D model (done); Make Drawings (done); Pressure system analysis (done); Check Drawings (done); Release drawing package; Issue procurment (done)
- 2562805a: Steps: Eng concept/develop requirements (done); 3D model (done); Make Drawings (done); Pressure system analysis (done); Check Drawings (done); Release drawing package; Issue procurment (done)
- 2562830: Steps: Tack support in place (done); Attach manifols to solenoid (done); install pipe and valves (done); Pressure test and leak check (done); inspection of welds/brazes (done); install insulation (done)
- 2562830a: Steps: Tack support in place (done); Attach manifols to solenoid (done); install pipe and valves (done); Pressure test and leak check (done); inspection of welds/brazes (done); install insulation (done)
- 2562835: Steps: survey and mark stand location (done); drill mounting holes in deck (done); install stand (done); install SEG blocks; Install lead
- 2562895: Steps: SC solenoid quench review support (done); SC solenoid technical documentation; SC solenoid performance analysis; SC solenoid performance evaluation/review material; SC solenoid operation optimization; SC solenoid operation documentation; SC solenoid procedures reviewing; SC power supply documentation; PS magnet operation documentation; Warm magnets power supply documentation; Tagget beam line technical documentation; Tagger beam line operation documentation; Hall D beamline technical docs; Hall D beamline technical docs1; DC technical and operation docs; ECAL technical and operation docs; OSP, ESAD for April beam
- 2562895a: Steps: SC solenoid quench review support (done); SC solenoid technical documentation; SC solenoid performance analysis; SC solenoid performance evaluation/review material; SC solenoid operation optimization; SC solenoid operation documentation; SC solenoid procedures reviewing; SC power supply documentation; PS magnet operation documentation; Warm magnets power supply documentation; Tagget beam line technical documentation; Tagger beam line operation documentation; Hall D beamline technical docs; Hall D beamline technical docs1; DC technical and operation docs; ECAL technical and operation docs; OSP, ESAD for April beam
- 2562098: Steps: mark floor for stand locations (done); Drill floor and install anchors; set stands; install and align cartridges; retrieve magnet from storage; install magnet; hook up power and water; test magnet operation
- 2562715: Steps: attach unistrut and hangers for chilled water lines (done); install pipe from north wall to detector manifold (done); install valves onto manifold (done); Pressure test and leak check (done); install insulation
- 2562061: Steps: Install rails (done); Fiducialize probe locations; Program and Test systems (done); Power magnet andcalibrate probes; map field
- 2562393: Steps: install outdoor gas bottle system; run gas lines to gas shed from outside; extend electrical power in gas shed; install racks inside gas shed (done); install alcohol system inside refrig (done); install mixing tanks inside gas shed (done); connect all plumbing lines in gas shed (done); Install 1/2 inch lines from gas shed to gas panel; install gas panel in Hall (done); install FDC manual valve panel; Install CDC manual valve panel; install electronic controls and UPS in racks; purge and leak check system; Test system operation
- 2562231: Steps: 3D model (done); structural/pressure system analysis (done); Make Drawings (done); Check Drawings; Release drawing package; Issue procurment
- 2562233: Steps: measure lateral gap at 4 plcs (done); update shim drawings; modify shims; glue shims in place
- 2562245: Steps: bring racks to hall North (done); attach vertical cable management panels (done); install in final position (done)
- 2562250: Steps: install conduit from panels to all racks north; install conduit from panels to all racks south; pull cable; install outlets in racks south (done); Test all circuits
- 2562250a: Steps: install conduit from panels to all racks north; install conduit from panels to all racks south; pull cable; install outlets in racks south (done); Test all circuits
- 2562250b: Steps: install conduit from panels to all racks north; install conduit from panels to all racks south; pull cable; install outlets in racks south (done); Test all circuits
- 2562335: Steps: install conduit from panels to BCAL racks (done); pull cable (done); Test all circuits
- 2562335a: Steps: install conduit from panels to BCAL racks (done); pull cable (done); Test all circuits
- 2562335b: Steps: install conduit from panels to BCAL racks (done); pull cable (done); Test all circuits
- 2562405: Steps: install conduit from panels to FCAL racks (done); pull cable (done); Test all circuits
- 2562690: Steps: Check Drawings (done); Release drawing package
- 2562690a: Steps: Check Drawings (done); Release drawing package
- 2562740: Steps: Finalize requirements (done); 3D model; system analysis; Make Drawings; Check Drawings; Release drawing package; Issue procurment
- 2562890: Steps: __Install_Documentation_D2 (done); __Install_Documentation_N1&S1; __Install_Documentation_U2; __Install_Documentation_U1; __Install_Documentation_US1; __BCAL_Readout_QC_Measurements; __FDC_Readout_QC_Measurements; __CDC_Readout_QC_Measurements; __PS_ST_Readout_QC_Measurements; __Beam_Profiler_Readout_QC_Measurements; __EMI_Noise_QC_Survey; __Operations_Readiness_QC
- 2562636: Steps: Finalize requirements (done); 3D model (done); system analysis (done); Make Drawings (done); Check Drawings; Release drawing package; Issue procurment
- 2562700: Steps: install duct work (done); install power; install blower (done); check system performance
- 2562246: Steps: bring racks to hall (done); attach vertical cable management panels (done); attach to floor
- 2562085: Steps: __position_on_floor
- 2562181: Steps: install beamtube and valves; leak check beamline
- 2562181a: Steps: install beamtube and valves; leak check beamline

| ID | Activity | Type | Duration | Start | Finish | Predecessors | Total float | Free float | Calendar | Resources | Cost | Original Activity ID Rebaseline | MONTHLY EV COST | RESP - Responsibility | STRT%COMP for CM EVM | FNSH%COMP for CM EVM | HALL D Related Milestones | CR 07-024 | CR 07-027 | Advance Purchase Plan > 500K | EVMS Reporting Codes | CAM RESPONSIBLE | CR 09-012 | CR 09-045 | CR 11-006 | CR 11-026 | CR 11-049 | CR 12-021 | CR 12-054 | BOE Procurement | BOE Labor | CR 13-015 | Post Rebaseline | Activities with Steps | CR 09-014 | CR 13-007 | Remaining Material Cost Based on % Compl | Claimed Material Cost Based on % Complet | Initial Claimed Material Calc | Claimed Material Divider | CR 14-001 | CR 10-042 | CR 11-044 | BOE Expenses | 12 GeV 1st level Critical Path | CR 11-004 | CR 08-052 | Milestone Level | CR 12-049 | CR 11-030 | CR 11-040 | CR 11-054 |
| --- | --- | --- | --- | --- | --- | --- | --- | --- | --- | --- | --- | --- | --- | --- | --- | --- | --- | --- | --- | --- | --- | --- | --- | --- | --- | --- | --- | --- | --- | --- | --- | --- | --- | --- | --- | --- | --- | --- | --- | --- | --- | --- | --- | --- | --- | --- | --- | --- | --- | --- | --- | --- |
| 2562355a | Install Supprt Electrnc's Platform #2 (Installtn) - Labor FY13 |  | 20d | 2013-11-01 | 2013-12-02 | 9-130M FS+228d | 179d | 0d | 8/5 M-F w/JLAB Holidays ReBaseline | MECH TECH [106.67 h] | 5,047.62 | 2562355 | 0 | CHUDAKOV | 1 | 1 | D | 07-024 | 07-027 | APP | U | EUGENE C | 09-012 | 09-045 | 11-006 | 11-026 | 11-049 | 12-021 | 12-054 | EJ | EJ | 13-015 | PR |  |  |  |  |  |  |  |  |  |  |  |  |  |  |  |  |  |  |  |
| 2562478 | FCAL DAQ and Trigger_Setup FY13 |  | 20d | 2013-11-01 | 2013-12-02 | 2562475ca, 2562475c FS-62d | 40d | 0d | 8/5 M-F w/JLAB Holidays ReBaseline | ELEC TECH [6.84 h]; SCIENTIST [47.87 h]; MECH TECH [13.68 h] | 4,567.04 | 2562478 | 0 | CHUDAKOV | 1 | 1 | D | 07-024 |  |  | S | EUGENE C |  |  | 11-006 | 11-026 |  |  |  |  | EJ | 13-015 | PR | ST | 09-014 | 13-007 |  |  |  |  |  |  |  |  |  |  |  |  |  |  |  |  |
| 2562482 | Test and analyze FCAL detector FY13 |  | 20d | 2013-11-01 | 2013-12-02 | 2562478 FS-117d, 2562478a FS-117d | 40d | 0d | 8/5 M-F w/JLAB Holidays ReBaseline | SCIENTIST [30.43 h] | 2,287.73 | 2562482 | 0 | CHUDAKOV | 1 | 1 | D | 07-024 |  |  | S | EUGENE C |  |  | 11-006 | 11-026 |  |  | 12-054F |  | EJ | 13-015 | PR | ST | 09-014 | 13-007 |  |  |  |  |  |  |  |  |  |  |  |  |  |  |  |  |
| 2562745 | Fabricate dry air cooling system up racks/drift chambers |  | 28d | 2013-11-01 | 2013-12-12 | 2562740 FS-18d | 135d | 22d | 8/5 M-F w/JLAB Holidays ReBaseline | PROCUREMENT<$50K 60 | 8,306.8 | 2562745 | 0 | CHUDAKOV | 1 | 1 | D |  |  |  | S | EUGENE C |  |  |  |  |  |  |  | EJ |  | 13-015 | PR | ST |  | 13-007 | 8306.8 | 0 | 0 | 100 | 14-001 |  |  |  |  |  |  |  |  |  |  |  |
| 2562770 | Manufacturing Drawings of fixture for commissioning target |  | 52d | 2013-11-01 | 2014-01-28 | 9-140M FS+13d | 118d | 0d | 8/5 M-F w/JLAB Holidays ReBaseline | MECH ENG [160 h]; MECH DES [240 h] | 24,259.2 | 2562770 | 0 | CHUDAKOV | 1 | 1 | D |  |  |  | S | EUGENE C |  |  |  |  |  |  |  |  | PE | 13-015 | PR | ST |  | 13-007 |  |  |  |  | 14-001 |  |  |  |  |  |  |  |  |  |  |  |
| 2562850 | Procure UPS system for critical controls |  | 67d | 2013-11-01 | 2014-02-18 | 9-140M FS+11d | 153d | 0d | 8/5 M-F w/JLAB Holidays ReBaseline | PROCUREMENT<$50K 60 | 4,746.74 | 2562850 | 0 | CHUDAKOV | 1 | 1 | D |  |  |  | D | EUGENE C |  |  |  |  |  |  |  | EJ |  | 13-015 | PR |  |  | 13-007 | 4746.74 | 0 | 0 | 100 | 14-001 |  |  |  |  |  |  |  |  |  |  |  |
| 2562875 | Develop flammable gas detection system in solenoid |  | 46d | 2013-11-01 | 2014-01-17 | 9-140M FS+23d | 99d | 0d | 8/5 M-F w/JLAB Holidays ReBaseline | MECH ENG [156 h]; MECH DES [152 h] | 19,446.12 | 2562875 | 0 | CHUDAKOV | 1 | 1 | D |  |  |  | S | EUGENE C |  |  |  |  |  |  |  |  | EJ | 13-015 | PR | ST |  | 13-007 |  |  |  |  | 14-001 |  |  |  |  |  |  |  |  |  |  |  |
| 2562270 | Install Supprt Electrnc's, Platform #1 (Installtn) |  | 43d | 2013-11-04 | 2014-01-15 | 9-140M FS+24d | 82d | 80d | 8/5 M-F w/JLAB Holidays ReBaseline | ELEC TECH [240 h]; PLABOR | 19,998.5 | 2562270 | 0 | CHUDAKOV | 1 | 1 | D | 07-024 | 07-027 |  | S | EUGENE C |  |  | 11-006 | 11-026 |  |  | 12-054 |  | EJ | 13-015 | PR |  | 09-014 | 13-007F |  |  |  |  | 14-001 | 10-042 | 11-044 | EJ |  |  |  |  |  |  |  |  |
| 2562625 | Install Electrical Dirty Power cable/conduit from Panels |  | 68d | 2013-11-04 | 2014-02-20 | 2562626 FS-23d, 2562620aa FS-55d, 2562620a FS-55d, 9-140M FS+24d | 155d |  | 8/5 M-F w/JLAB Holidays ReBaseline | MECH TECH [306 h]; MECH ENG [12 h] | 15,375.96 | 2562625 | 0 | CHUDAKOV | 1 | 1 | D |  |  |  | S | EUGENE C |  |  | 11-006 | 11-026 |  | 12-021 |  |  | PE | 13-015 | PR | ST |  |  |  |  |  |  | 14-001 |  |  |  | 1 |  |  |  |  |  |  |  |
| 2562840 | Install dirty power cable/conduit tagger |  | 33d | 2013-11-04 | 2013-12-20 | 9-140M FS+24d | 177d | 0d | 8/5 M-F w/JLAB Holidays ReBaseline | SUPPLIES & MATERIALS; MECH TECH [114 h] | 7,159.03 | 2562840 | 0 | CHUDAKOV | 1 | 1 | D |  |  |  | S | EUGENE C |  |  |  |  |  |  |  |  | EJ | 13-015 | PR | ST |  | 13-007 |  |  |  |  | 14-001 |  |  | PE |  |  |  |  |  |  |  |  |
| 2562278 | BCAL DAQ Control and Trigger set-up |  | 41d | 2013-11-05 | 2014-01-14 | 2562275c FS-32d | 63d | 0d | 8/5 M-F w/JLAB Holidays ReBaseline | SCIENTIST [360 h] | 27,064.8 | 2562278 | 0 | CHUDAKOV | 1 | 1 | D | 07-024 |  |  | S | EUGENE C |  |  | 11-006 | 11-026 |  | 12-021 | 12-054 |  | EJ | 13-015 | PR | ST | 09-014 | 13-007 |  |  |  |  | 14-001 |  |  |  |  |  |  |  |  |  |  |  |
| 2562880 | Procure flammable gas detection system |  | 53d | 2013-11-05 | 2014-01-31 | 2562875 FS-44d | 99d | 0d | 8/5 M-F w/JLAB Holidays ReBaseline | PROCUREMENT<$50K 60 | 8,461.58 | 2562880 | 0 | CHUDAKOV | 1 | 1 | D |  |  |  | D | EUGENE C |  |  |  |  |  |  |  | EJ |  | 13-015 | PR |  |  | 13-007 | 8461.58 | 0 | 0 | 100 | 14-001 |  |  |  |  |  |  |  |  |  |  |  |
| 2562545 | Crates - Loaded (VME64x VXS HV LV) Install Hall TOF |  | 5d | 2013-11-15 | 2013-11-21 | 2548025, 2548025a, 2562540 | 189d | 125d | 8/5 M-F w/JLAB Holidays ReBaseline | ELEC TECH [80 h] | 3,759.2 | 2562545 | 0 | CHUDAKOV | 1 | 1 | D |  |  |  | U | EUGENE C |  |  | 11-006 | 11-026 |  | 12-021 | 12-054 |  | PE | 13-015 | PR |  |  |  |  |  |  |  | 14-001 |  |  |  | 1 |  |  |  |  |  |  |  |
| 2562180 | Install Photon BL Tag Hall (Installtn) |  | 24d | 2013-11-22 | 2014-01-08 | 2562098 FS-80d, 2553017 FS-1d, 2553175 FS-40d | 185d |  | 8/5 M-F w/JLAB Holidays ReBaseline | MECH TECH [85.12 h]; SUPPLIES & MATERIALS; MECH ENG [11.2 h]; PROCUREMENT<$50K 60 | 6,723.93 | 2562180 | 0 | CHUDAKOV | 1 | 1 | D | 07-024 |  | APP | S | EUGENE C |  |  | 11-006 | 11-026 |  | 12-021 | 12-054 | PE | PE | 13-015 | PR | ST | 09-014 | 13-007 | 1744.18 | 0 | 0 | 100 | 14-001 |  |  | EJ |  | 11-004 |  |  |  |  |  |  |
| 2562232 | Fab BCAL lateral support |  | 22d | 2013-11-26 | 2014-01-08 | 2562231 FS-3d | 181d | 21d | 8/5 M-F w/JLAB Holidays ReBaseline | PROCUREMENT<$50K 60 | 3,921.22 | 2562232 | 0 | CHUDAKOV | 1 | 1 | D |  |  |  | D | EUGENE C |  |  |  |  |  |  |  | PE |  | 13-015 | PR |  |  | 13-007 | 3921.22 | 0 | 0 | 100 | 14-001 |  |  |  |  |  |  |  |  |  |  |  |
| 2562870 | Install lighting fixtures under US platform |  | 23d | 2013-11-27 | 2014-01-10 | 2562865 FS+26d | 113d | 0d | 8/5 M-F w/JLAB Holidays ReBaseline | MECH TECH [88 h] | 4,164.16 | 2562870 | 0 | CHUDAKOV | 1 | 1 | D |  |  |  | S | EUGENE C |  |  |  |  |  |  |  |  | PE | 13-015 | PR | ST |  | 13-007 |  |  |  |  | 14-001 |  |  |  |  |  |  |  |  |  |  |  |
| 2562370 | Cables - Install on Trays Detector to Racks FDC |  | 20d | 2013-12-02 | 2014-01-08 | 2547165, 2547170, 2562365 FS+7d, 2547165a, 2547170a | 16d | 0d | 8/5 M-F w/JLAB Holidays ReBaseline | ELEC TECH [120 h]; MECH TECH [160 h]; SCIENTIST | 13,210 | 2562370 | 0 | CHUDAKOV | 1 | 1 | D | 07-024 |  | APP | U | EUGENE C |  |  | 11-006 | 11-026 |  | 12-021 | 12-054 |  | PE | 13-015 | PR |  | 09-014 | 13-007 |  |  |  |  | 14-001 | 10-042 |  |  |  |  | 08-052 |  |  |  |  |  |
| 2562370a | Cables - Route and Connect on Detector FDC |  | 28d | 2013-12-02 | 2014-01-21 | 2562370 FS-20d | 19d | 0d | 8/5 M-F w/JLAB Holidays ReBaseline | ELEC TECH [240 h]; MECH TECH; SCIENTIST | 11,277.6 | 2562370a | 0 | CHUDAKOV | 1 | 1 | D | 07-024 |  |  | U | EUGENE C |  |  | 11-006 | 11-026 |  | 12-021 | 12-054 |  | PE | 13-015 | PR |  | 09-014 | 13-007 |  |  |  |  | 14-001 |  |  |  |  |  |  |  |  |  |  |  |
| 2562035M | Assy of TOF (Installtn) | milestone | 0d | 2013-12-03 | 2013-12-03 | 2561060M | 162d | 98d | 8/5 M-F w/JLAB Holidays ReBaseline |  |  | 2562035M | 0 | CHUDAKOV | 1 | 1 | D |  |  |  | M | EUGENE C |  |  | 11-006 | 11-026 |  | 12-021 | 12-054 |  |  | 13-015 | PR |  | 09-014 | 13-007F |  |  |  |  |  |  |  |  |  |  |  | 6 | 12-049 |  |  |  |
| 2562085a | Racks - Install Tagger FY14 |  | 9d | 2013-12-03 | 2013-12-13 | 2562085 | 126d | 8d | 8/5 M-F w/JLAB Holidays ReBaseline | ELEC TECH [0.37 h]; SUPPLIES & MATERIALS; MECH TECH [3.35 h] | 185.52 | 2562085 | 0 | CHUDAKOV | 1 | 1 | D | 07-024 |  |  | S | EUGENE C |  |  | 11-006 | 11-026 |  |  | 12-054 |  | PE | 13-015 | PR | ST | 09-014 | 13-007F |  |  |  |  | 14-001 |  | 11-044 | EJ |  |  |  |  |  |  |  |  |
| 2562181b | Install Photon BL Colli. Cave (Installtn) - Labor/Expenses FY14 |  | 57d | 2013-12-03 | 2014-03-04 | 2562181a | 147d |  | 8/5 M-F w/JLAB Holidays ReBaseline | MECH TECH [51.52 h]; SUPPLIES & MATERIALS; MECH ENG [5.15 h] | 2,911.14 | 2562181 | 0 | CHUDAKOV | 1 | 1 | D | 07-024 |  | APP | S | EUGENE C |  |  | 11-006 | 11-026 |  | 12-021 | 12-054 | PE | PE | 13-015 | PR | ST | 09-014 | 13-007 |  |  |  |  | 14-001 |  |  | EJ |  |  |  |  |  |  |  |  |
| 2562355b | Install Supprt Electrnc's Platform #2 (Installtn) - Labor FY14 |  | 25d | 2013-12-03 | 2014-01-16 | 2562355a | 179d |  | 8/5 M-F w/JLAB Holidays ReBaseline | MECH TECH [133.34 h] | 6,309.65 | 2562355 | 0 | CHUDAKOV | 1 | 1 | D | 07-024 | 07-027 | APP | U | EUGENE C | 09-012 | 09-045 | 11-006 | 11-026 | 11-049 | 12-021 | 12-054 | EJ | EJ | 13-015 | PR |  |  |  |  |  |  |  | 14-001 |  |  |  |  |  |  |  |  |  |  |  |
| 2562478a | FCAL DAQ and Trigger_Setup FY14 |  | 97d | 2013-12-03 | 2014-04-29 | 2562478, 2562475ca FS-62d | 40d | 0d | 8/5 M-F w/JLAB Holidays ReBaseline | ELEC TECH [33.16 h]; SCIENTIST [232.13 h]; MECH TECH [66.32 h] | 22,148.56 | 2562478 | 0 | CHUDAKOV | 1 | 1 | D | 07-024 |  |  | S | EUGENE C |  |  | 11-006 | 11-026 |  |  |  |  | EJ | 13-015 | PR | ST | 09-014 | 13-007 |  |  |  |  | 14-001 |  |  |  |  |  |  |  |  |  |  |  |
| 2562482a | Test and analyze FCAL detector FY14 |  | 164d | 2013-12-03 | 2014-08-04 | 2562478a FS-117d, 2562482 | 40d |  | 8/5 M-F w/JLAB Holidays ReBaseline | SCIENTIST [249.57 h] | 18,762.67 | 2562482 | 0 | CHUDAKOV | 1 | 1 | D | 07-024 |  |  | S | EUGENE C |  |  | 11-006 | 11-026 |  |  | 12-054F |  | EJ | 13-015 | PR | ST | 09-014 | 13-007 |  |  |  |  | 14-001 |  |  |  |  |  |  |  |  |  |  |  |
| 2562060 | Survey & Align tagger beamline (Installtn) |  | 16d | 2013-12-06 | 2014-01-08 | 2562440, 2562045a FS+12d, 2562045 FS+12d | 185d | 167d | 8/5 M-F w/JLAB Holidays ReBaseline | MECH TECH [45.92 h]; MECH ENG [9.84 h] | 2,907.68 | 2562060 | 0 | CHUDAKOV | 1 | 1 | D | 07-024 |  |  | S | EUGENE C |  |  | 11-006 | 11-026 |  |  | 12-054 |  | PE | 13-015 | PR | ST | 09-014 |  |  |  |  |  | 14-001 |  |  |  |  |  |  |  |  | 11-030 |  |  |
| 2562520 | Crates - Loaded (VME64x VXS HV LV) Install Hall Pair Spectrometer |  | 5d | 2013-12-09 | 2013-12-13 | 2548025 FS+32d, 2548025a FS+32d | 183d | 0d | 8/5 M-F w/JLAB Holidays ReBaseline | ELEC TECH [80 h] | 3,759.2 | 2562520 | 0 | CHUDAKOV | 1 | 1 | D |  |  |  | U | EUGENE C |  |  | 11-006 | 11-026 |  | 12-021 | 12-054 |  | PE | 13-015 | PR |  |  |  |  |  |  |  | 14-001 |  |  |  | 1 |  |  |  |  |  |  |  |
| 2562525 | Crates - Loaded (VME64x VXS HV LV) Install Hall Start Counter |  | 5d | 2013-12-16 | 2013-12-20 | 2562520, 2548025, 2548025a | 183d | 153d | 8/5 M-F w/JLAB Holidays ReBaseline | ELEC TECH [80 h] | 3,759.2 | 2562525 | 0 | CHUDAKOV | 1 | 1 | D |  |  |  | U | EUGENE C |  |  | 11-006 | 11-026 |  | 12-021 | 12-054 |  | PE | 13-015 | PR |  |  |  |  |  |  |  | 14-001 |  |  |  | 1 |  |  |  |  |  |  |  |
| 2562775 | Fab Fixture for commissioning target |  | 48d | 2013-12-19 | 2014-03-07 | 2562770 FS-20d | 118d | 0d | 8/5 M-F w/JLAB Holidays ReBaseline | PROCUREMENT<$50K 60 | 8,255.2 | 2562775 | 0 | CHUDAKOV | 1 | 1 | D |  |  |  | D | EUGENE C |  |  |  |  |  |  |  | PE |  | 13-015 | PR |  |  | 13-007 | 8255.2 | 0 | 0 | 100 | 14-001 |  |  |  |  |  |  |  |  |  |  |  |
| 2562855 | Install UPS system for critical controls |  | 38d | 2013-12-20 | 2014-02-24 | 2562850 FS-34d | 153d |  | 8/5 M-F w/JLAB Holidays ReBaseline | MECH TECH [200 h] | 9,464 | 2562855 | 0 | CHUDAKOV | 1 | 1 | D |  |  |  | S | EUGENE C |  |  |  |  |  |  |  |  | PE | 13-015 | PR | ST |  | 13-007 |  |  |  |  | 14-001 |  |  |  |  |  |  |  |  |  |  |  |
| 2562099a | Cables - Route and Connect on Detector Pair Spectrometer |  | 10d | 2014-01-02 | 2014-01-15 | 9-140M FS+59d, 2562099 | 152d | 0d | 8/5 M-F w/JLAB Holidays ReBaseline | SCIENTIST; ELEC TECH [80 h] | 3,759.2 | 2562099a | 0 | CHUDAKOV | 1 | 1 | D | 07-024 |  |  | U | EUGENE C |  |  | 11-006 | 11-026 |  | 12-021 |  |  | PE | 13-015 | PR |  | 09-014 | 13-007 |  |  |  |  | 14-001 |  |  |  |  |  |  |  |  |  |  |  |
| 2562845 | Install Power cable/conduit tagger |  | 33d | 2014-01-02 | 2014-02-18 | 2562840 | 177d | 53d | 8/5 M-F w/JLAB Holidays ReBaseline |  |  | 2562845 | 0 | CHUDAKOV | 1 | 1 | D |  |  |  | S | EUGENE C |  |  |  |  |  |  |  |  |  | 13-015 | PR |  |  | 13-007 |  |  |  |  |  |  |  |  |  |  |  |  |  |  |  |  |
| 2562090 | Install Tagger Electrnc's (Installtn) |  | 10d | 2014-01-03 | 2014-01-16 | 9-140M FS+60d | 130d | 63d | 8/5 M-F w/JLAB Holidays ReBaseline | ELEC ENG [8 h]; ELEC TECH [240 h]; PLABOR | 16,862 | 2562090 | 0 | CHUDAKOV | 1 | 1 | D | 07-024 |  |  | S | EUGENE C |  |  | 11-006 | 11-026 |  |  | 12-054 |  | PE | 13-015 | PR |  | 09-014 | 13-007 |  |  |  |  | 14-001 |  | 11-044 | EJ |  |  |  |  |  |  |  |  |
| 2562635 | Install air lines in hall D |  | 45d | 2014-01-03 | 2014-03-07 | 9-140M FS+60d | 144d |  | 8/5 M-F w/JLAB Holidays ReBaseline | MECH TECH [289.2 h]; MECH ENG [4 h] | 13,983.62 | 2562635 | 0 | CHUDAKOV | 1 | 1 | D |  |  |  | S | EUGENE C |  |  | 11-006 | 11-026 |  | 12-021 |  |  | PE | 13-015 | PR | ST |  |  |  |  |  |  | 14-001 |  |  |  | 1 |  |  |  |  |  |  |  |
| 2562637 | Procure Inst Air Sys |  | 30d | 2014-01-03 | 2014-02-14 | 2562636 | 159d |  | 8/5 M-F w/JLAB Holidays ReBaseline | SUPPLIES & MATERIALS | 4,746.74 | 2562637 | 0 | CHUDAKOV | 1 | 1 | D |  |  |  | D | EUGENE C |  |  | 11-006 | 11-026 |  | 12-021 |  |  |  | 13-015 | PR |  |  |  |  |  |  |  | 14-001 |  |  | EJ | 1 |  |  |  |  |  |  |  |
| 2562860 | Install Electron beamline to dump |  | 31d | 2014-01-06 | 2014-02-18 | 9-140M FS+61d | 157d |  | 8/5 M-F w/JLAB Holidays ReBaseline | MECH TECH [144 h]; SUPPLIES & MATERIALS; MECH ENG [8 h]; MECH DES [4 h] | 7,823.02 | 2562860 | 0 | CHUDAKOV | 1 | 1 | D |  |  |  | S | EUGENE C |  |  |  |  |  |  |  |  | PE | 13-015 | PR | ST |  | 13-007 |  |  |  |  | 14-001 |  |  | EJ |  |  |  |  |  |  |  |  |
| 2562065 | Install Pwr for Tagger Electrnc's (Installtn) |  | 20d | 2014-01-07 | 2014-02-04 | 2562085a, 2562085, 9-140M FS+62d | 118d | 51d | 8/5 M-F w/JLAB Holidays ReBaseline | MECH TECH [136 h]; ELEC TECH [4 h]; ELEC ENG [8 h] | 7,224.52 | 2562065 | 0 | CHUDAKOV | 1 | 1 | D |  |  | APP | S | EUGENE C |  |  | 11-006 | 11-026 |  | 12-021 | 12-054 |  | PE | 13-015 | PR | ST | 09-014 |  |  |  |  |  | 14-001 |  | 11-044 |  |  |  |  |  |  |  |  |  |
| 2562750 | Install dry air cooling system up racks/drift chamber |  | 32d | 2014-01-13 | 2014-02-26 | 2562745 FS-9d, 2562870 | 113d | 2d | 8/5 M-F w/JLAB Holidays ReBaseline | MECH TECH [272 h]; MECH ENG [24 h] | 14,663.12 | 2562750 | 0 | CHUDAKOV | 1 | 1 | D |  |  |  | S | EUGENE C |  |  |  |  |  |  |  |  | EJ | 13-015 | PR | ST |  | 13-007 |  |  |  |  | 14-001 |  |  |  |  |  |  |  |  |  |  |  |
| 2562370b | Cables - Route on Racks FDC |  | 14d | 2014-01-14 | 2014-02-03 | 2562730a FS-15d, 2562730 FS-15d, 2562370a FS-5d | 19d | 0d | 8/5 M-F w/JLAB Holidays ReBaseline | ELEC TECH [120 h]; MECH TECH [120 h]; SCIENTIST | 11,317.2 | 2562370b | 0 | CHUDAKOV | 1 | 1 | D | 07-024 |  |  | U | EUGENE C |  |  | 11-006 | 11-026 |  | 12-021 | 12-054 |  | PE | 13-015 | PR |  | 09-014 | 13-007 |  |  |  |  | 14-001 |  |  |  |  |  |  |  |  |  |  |  |
| 2562370c | Cables - Connect to Crate Electronics FDC |  | 48d | 2014-01-14 | 2014-03-21 | 2562370b FS-14d | 19d | 0d | 8/5 M-F w/JLAB Holidays ReBaseline | ELEC TECH [80 h]; MECH TECH; SCIENTIST; ELEC ENG [40 h] | 6,764.4 | 2562370c | 0 | CHUDAKOV | 1 | 1 | D | 07-024 |  |  | U | EUGENE C |  |  | 11-006 | 11-026 |  | 12-021 | 12-054 |  | PE | 13-015 | PR |  | 09-014 | 13-007 |  |  |  |  | 14-001 |  |  |  |  |  |  |  |  |  |  |  |
| 2562281 | Analyze BCAL Performance inside solenoid |  | 118d | 2014-01-15 | 2014-07-01 | 2562278 | 63d |  | 8/5 M-F w/JLAB Holidays ReBaseline | SCIENTIST [320 h] | 24,057.6 | 2562281 | 0 | CHUDAKOV | 1 | 1 | D | 07-024 |  |  | S | EUGENE C |  |  | 11-006 | 11-026 |  | 12-021 | 12-054 |  | PE | 13-015 | PR | ST | 09-014 | 13-007 |  |  |  |  | 14-001 | 10-042 |  |  | 1 |  |  |  |  |  |  |  |
| 2562099b | Cables - Route on Racks Pair Spectrometer |  | 5d | 2014-01-16 | 2014-01-23 | 2562099a | 152d | 0d | 8/5 M-F w/JLAB Holidays ReBaseline | ELEC TECH [40 h] | 1,879.6 | 2562099b | 0 | CHUDAKOV | 1 | 1 | D | 07-024 |  |  | U | EUGENE C |  |  | 11-006 | 11-026 |  | 12-021 |  |  | PE | 13-015 | PR |  | 09-014 | 13-007 |  |  |  |  | 14-001 |  |  |  |  |  |  |  |  |  |  |  |
| 2562290 | Cables - Install on Trays Detector to Racks CDC |  | 6d | 2014-01-17 | 2014-01-27 | 2562330, 2547135 FS+20d | 111d | 0d | 8/5 M-F w/JLAB Holidays ReBaseline | SCIENTIST; ELEC TECH [120 h]; MECH TECH [80 h] | 9,424.4 | 2562290 | 0 | CHUDAKOV | 1 | 1 | D | 07-024 |  |  | U | EUGENE C |  |  | 11-006 | 11-026 |  | 12-021 | 12-054 |  | PE | 13-015 | PR |  | 09-014 | 13-007 |  |  |  |  | 14-001 | 10-042 |  |  | 1 |  |  |  |  |  |  |  |
| 2562290a | Cables - Route and Connect on Detector CDC |  | 20d | 2014-01-22 | 2014-02-18 | 2562290 FS-4d | 111d | 0d | 8/5 M-F w/JLAB Holidays ReBaseline | SCIENTIST; ELEC TECH [200 h]; MECH TECH [120 h] | 15,076.4 | 2562290a | 0 | CHUDAKOV | 1 | 1 | D | 07-024 |  |  | U | EUGENE C |  |  | 11-006 | 11-026 |  | 12-021 | 12-054 |  | PE | 13-015 | PR |  | 09-014 | 13-007 |  |  |  |  | 14-001 |  |  |  |  |  |  |  |  |  |  |  |
| 2562099c | Cables - Connect to Crate Electronics Pair Spectrometer |  | 10d | 2014-01-24 | 2014-02-06 | 2562099b | 152d | 0d | 8/5 M-F w/JLAB Holidays ReBaseline | ELEC TECH [40 h]; ELEC ENG [40 h] | 4,884.8 | 2562099c | 0 | CHUDAKOV | 1 | 1 | D | 07-024 |  |  | U | EUGENE C |  |  | 11-006 | 11-026 |  | 12-021 |  |  | PE | 13-015 | PR |  | 09-014 | 13-007 |  |  |  |  | 14-001 |  |  |  |  |  |  |  |  |  |  |  |
| 2562216 | Field Map PS magnet |  | 32d | 2014-01-24 | 2014-03-10 | 2562214 | 143d |  | 8/5 M-F w/JLAB Holidays ReBaseline | MECH ENG [88 h]; MECH TECH [120 h] | 12,249.36 | 2562216 | 0 | CHUDAKOV | 1 | 1 | D |  |  | APP | S | EUGENE C |  |  |  |  |  |  |  |  | PE | 13-015 | PR | ST |  | 13-007 |  |  |  |  | 14-001 |  |  |  | 1 |  |  |  |  |  |  |  |
| 2562170 | Install Photon Beam Profiler (Installtn) |  | 24d | 2014-01-29 | 2014-03-03 | 2553055 FS+5d | 148d |  | 8/5 M-F w/JLAB Holidays ReBaseline | MECH TECH [96 h]; PLABOR; SUPPLIES & MATERIALS; SCIENTIST [80 h]; MECH ENG [20 h]; MECH DES [8 h] | 12,564.11 | 2562170 | 0 | CHUDAKOV | 1 | 1 | D | 07-024 |  |  | S | EUGENE C |  |  | 11-006 | 11-026 |  | 12-021 | 12-054 |  | PE | 13-015 | PR | ST |  | 13-007 |  |  |  |  | 14-001 |  |  | EJ |  | 11-004 |  |  |  |  |  |  |
| 2562420 | Install Supprt Electrnc's FCAL/TOF Racks (Installtn) |  | 41d | 2014-01-30 | 2014-03-27 | 9-140M FS+78d | 130d |  | 8/5 M-F w/JLAB Holidays ReBaseline | PLABOR; ELEC TECH [240 h] | 23,736.03 | 2562420 | 0 | CHUDAKOV | 1 | 1 | D | 07-024 | 07-027 |  | S | EUGENE C |  | 09-045 | 11-006 | 11-026 | 11-049 | 12-021 | 12-054 |  | EJ | 13-015 | PR |  |  |  |  |  |  |  | 14-001 |  |  | EJ |  |  |  |  |  |  |  |  |
| 2562205 | Install NIM and CAEN Crates in Counting Room (Installtn) |  | 20d | 2014-02-03 | 2014-02-28 | 2531070 FS-1d, 2531077, 2531047 | 2d | 0d | 8/5 M-F w/JLAB Holidays ReBaseline | ELEC TECH [80 h]; SCIENTIST [80 h] | 9,773.6 | 2562205 | 0 | CHUDAKOV | 1 | 1 | D | 07-024 |  | APP | U | EUGENE C |  |  | 11-006 | 11-026 |  | 12-021 | 12-054F |  | PE | 13-015 | PR |  |  | 13-007F |  |  |  |  | 14-001 | 10-042 |  |  |  |  |  |  |  |  |  |  |
| 2562380 | Insertion of FDC (Installtn) |  | 7d | 2014-02-07 | 2014-02-17 | 282462005 | 16d | 0d | 8/5 M-F w/JLAB Holidays ReBaseline | ELEC ENG [8 h]; PROCUREMENT<$50K 60; MECH TECH [160 h]; ELEC TECH [80 h]; MECH ENG [80 h] | 30,363.47 | 2562380 | 0 | CHUDAKOV | 1 | 1 | D | 07-024 |  | APP | S | EUGENE C |  |  | 11-006 | 11-026 |  | 12-021 | 12-054 | EJ | EJ | 13-015 | PR |  | 09-014 | 13-007 | 12458.43 | 0 | 0 | 100 | 14-001 | 10-042 |  |  |  |  |  |  |  |  |  |  |
| 2562235 | Comp B-cal Assy (Installtn) |  | 10d | 2014-02-12 | 2014-02-25 | 2562230, 2562245 FS+42d, 25221057c, 2562225, 2562233, 25221057ca, 2562830, 25221057b, 25221057ba, 2562230a | 152d |  | 8/5 M-F w/JLAB Holidays ReBaseline | MECH TECH [152 h]; MECH ENG [32 h]; PROCUREMENT<$50K 60 | 12,073.78 | 2562235 | 0 | CHUDAKOV | 1 | 1 | D | 07-024 |  | APP | S | EUGENE C |  |  | 11-006 | 11-026 |  | 12-021 | 12-054 | EJ | EJ | 13-015 | PR |  | 09-014 | 13-007 | 2491.7 | 0 | 0 | 100 | 14-001 | 10-042 |  |  | 1 |  |  |  |  |  | 11-040 | 11-054 |
| 2562290b | Cables - Route on Racks CDC |  | 7d | 2014-02-14 | 2014-02-24 | 2562290a FS-3d | 111d | 0d | 8/5 M-F w/JLAB Holidays ReBaseline | ELEC TECH [80 h] | 3,759.2 | 2562290b | 0 | CHUDAKOV | 1 | 1 | D | 07-024 |  |  | U | EUGENE C |  |  | 11-006 | 11-026 |  | 12-021 | 12-054 |  | PE | 13-015 | PR |  | 09-014 | 13-007 |  |  |  |  | 14-001 |  |  |  |  |  |  |  |  |  |  |  |
| 2562300 | Mounting CDC on cart align and insert into solenoid (Installtn) |  | 13d | 2014-02-18 | 2014-03-06 | 2562380, 2561110 | 16d | 0d | 8/5 M-F w/JLAB Holidays ReBaseline | MECH ENG [80 h]; MECH TECH [160 h]; SCIENTIST [40 h] | 16,552 | 2562300 | 0 | CHUDAKOV | 1 | 1 | D | 07-024 |  |  | S | EUGENE C |  |  | 11-006 | 11-026 |  | 12-021 | 12-054 |  | PE | 13-015 | PR | ST | 09-014 | 13-007 |  |  |  |  | 14-001 | 10-042 |  |  | 1 |  |  |  |  |  |  |  |
| 2562385 | Cooling Sys Checks for FDC (Installtn) |  | 8d | 2014-02-18 | 2014-02-27 | 2562380 | 23d | 0d | 8/5 M-F w/JLAB Holidays ReBaseline | MECH ENG [16 h]; MECH TECH [80 h] | 4,980.32 | 2562385 | 0 | CHUDAKOV | 1 | 1 | D | 07-024 |  |  | H | EUGENE C |  |  | 11-006 | 11-026 |  | 12-021 | 12-054 |  | EJ | 13-015 | PR |  | 09-014 | 13-007 |  |  |  |  | 14-001 | 10-042 |  |  |  |  |  |  |  |  |  |  |
| 2562290c | Cables - Connect to Crate Electronics CDC |  | 6d | 2014-02-21 | 2014-02-28 | 2562250b, 2562250, 2562290b FS-2d | 111d | 0d | 8/5 M-F w/JLAB Holidays ReBaseline | ELEC ENG [40 h]; ELEC TECH [80 h] | 6,764.4 | 2562290c | 0 | CHUDAKOV | 1 | 1 | D | 07-024 |  |  | U | EUGENE C |  |  | 11-006 | 11-026 |  | 12-021 | 12-054 |  | PE | 13-015 | PR |  | 09-014 | 13-007 |  |  |  |  | 14-001 |  |  |  |  |  |  |  |  |  |  |  |
| 2562206 | Install Computers in Counting Room (Installtn) Part B |  | 17d | 2014-03-03 | 2014-03-25 | 2531022, 2531027, 2562205 | 132d |  | 8/5 M-F w/JLAB Holidays ReBaseline | SCIENTIST [80 h]; ELEC TECH [80 h] | 9,773.6 | 2562206 | 0 | CHUDAKOV | 1 | 1 | D | 07-024 |  | APP | U | EUGENE C |  |  | 11-006 | 11-026 |  | 12-021 |  |  | PE | 13-015 | PR |  |  |  |  |  |  |  | 14-001 | 10-042 |  |  |  |  |  |  |  |  |  |  |
| 2562210 | Install Supprt Electrnc's in Counting Room (Installtn) (SP) |  | 20d | 2014-03-03 | 2014-03-28 | 2562205 | 2d | 0d | 8/5 M-F w/JLAB Holidays ReBaseline | PLABOR | 12,458.43 | 2562210 | 0 | CHUDAKOV | 1 | 1 | D | 07-024 |  |  | S | EUGENE C |  |  | 11-006 | 11-026 |  | 12-021 | 12-054F |  |  | 13-015 | PR |  |  | 13-007 |  |  |  |  | 14-001 | 10-042 |  | EJ |  |  |  |  |  |  |  |  |
| 2562165 | Install High Granularity Pair Spectrometer (Installtn) |  | 35d | 2014-03-06 | 2014-04-23 | 2553135 FS-19d, 2553125, 2553044, 2546470a FS-20d, 2546470 FS-20d | 111d |  | 8/5 M-F w/JLAB Holidays ReBaseline | MECH TECH [160 h]; MECH ENG [24 h]; SUPPLIES & MATERIALS; SCIENTIST [40 h] | 12,680.05 | 2562165 | 0 | CHUDAKOV | 1 | 1 | D | 07-024 |  | APP | S | EUGENE C |  |  | 11-006 | 11-026 |  | 12-021 | 12-054 |  | EJ | 13-015 | PR | ST | 09-014 | 13-007 |  |  |  |  | 14-001 |  |  | EJ |  |  |  |  |  |  |  |  |
| 2562303 | Install FDC/CDC Alignment Check System (Installtn) |  | 10d | 2014-03-06 | 2014-03-19 | 2562300 FS-1d | 33d | 31d | 8/5 M-F w/JLAB Holidays ReBaseline | MECH ENG [40 h]; MECH TECH [160 h] | 10,558 | 2562303 | 0 | CHUDAKOV | 1 | 1 | D | 07-024 |  |  | S | EUGENE C |  |  | 11-006 | 11-026 |  | 12-021 | 12-054 |  | EJ | 13-015 | PR | ST | 09-014 | 13-007 |  |  |  |  | 14-001 | 10-042 |  |  | 1 |  |  |  |  |  |  |  |
| 2562301 | CDC mounting electronics and other connections in situ (Installtn) |  | 15d | 2014-03-07 | 2014-03-27 | 2562300 | 16d | 14d | 8/5 M-F w/JLAB Holidays ReBaseline | MECH TECH [40 h]; MECH ENG [40 h]; SCIENTIST [80 h]; ELEC TECH [80 h] | 14,653.2 | 2562301 | 0 | CHUDAKOV | 1 | 1 | D | 07-024 |  |  | U | EUGENE C |  |  | 11-006 | 11-026 |  | 12-021 | 12-054 |  | EJ | 13-015 | PR |  | 09-014 | 13-007 |  |  |  |  | 14-001 | 10-042 |  |  | 1 |  |  |  |  |  |  |  |
| 2562885 | Install flammable gas detection system |  | 45d | 2014-03-10 | 2014-05-09 | 2562880 FS+25d | 99d |  | 8/5 M-F w/JLAB Holidays ReBaseline | MECH TECH [112 h]; MECH ENG [84 h]; MECH DES [4 h] | 11,777.32 | 2562885 | 0 | CHUDAKOV | 1 | 1 | D |  |  |  | S | EUGENE C |  |  |  |  |  |  |  |  | EJ | 13-015 | PR |  |  | 13-007 |  |  |  |  | 14-001 |  |  |  |  |  |  |  |  |  |  |  |
| 2562280 | Technical Support for Bcal Testing (Installtn) |  | 73d | 2014-03-11 | 2014-06-20 | 2562210 FS-14d, 2562275d, 2562270 FS-43d, 25221060 FS-16d, 2562275, 25221060a FS-16d | 2d | 0d | 8/5 M-F w/JLAB Holidays ReBaseline | ELEC ENG [80 h]; ELEC TECH [160 h] | 13,528.8 | 2562280 | 0 | CHUDAKOV | 1 | 1 | D | 07-024 |  |  | S | EUGENE C |  |  | 11-006 | 11-026 |  | 12-021 | 12-054 |  | PE | 13-015 | PR | ST | 09-014 | 13-007 |  |  |  |  | 14-001 | 10-042 |  |  | 1 |  |  |  |  |  |  |  |
| 2562780 | Install Commissioning target with Start Counter |  | 21d | 2014-03-17 | 2014-04-14 | 2562775 FS+5d | 118d |  | 8/5 M-F w/JLAB Holidays ReBaseline | MECH TECH [120 h]; SCIENTIST [48 h]; MECH ENG [12 h] | 10,183.08 | 2562780 | 0 | CHUDAKOV | 1 | 1 | D |  |  |  | S | EUGENE C |  |  |  |  |  |  |  |  | EJ | 13-015 | PR | ST |  | 13-007 |  |  |  |  | 14-001 |  |  |  |  |  |  |  |  |  |  |  |
| 2562505 | Install Trigger Electrnc's (Installtn) |  | 20d | 2014-03-19 | 2014-04-15 | 282443020a, 2543115 FS+16d, 282443020 | 78d | 59d | 8/5 M-F w/JLAB Holidays ReBaseline | ELEC TECH [200 h] | 9,398 | 2562505 | 0 | CHUDAKOV | 1 | 1 | D |  |  |  | U | EUGENE C |  |  | 11-006 | 11-026 |  | 12-021 |  |  | EJ | 13-015 | PR |  |  |  |  |  |  |  | 14-001 |  |  |  |  |  |  |  |  |  |  |  |
| 2562080 | Install Hodoscope (Installtn) |  | 10d | 2014-04-02 | 2014-04-15 | 2546585, 25512010a, 25512070, 2562061, 2546605b, 25512010aa, 2546600, 25512060, 25512010, 25512013LOE, 25512005a, 25512176, 2562440 FS-200d, 2546605, 2546585b | 67d | 0d | 8/5 M-F w/JLAB Holidays ReBaseline | SUPPLIES & MATERIALS; SCIENTIST [72 h]; MECH ENG [52 h]; MECH TECH [344 h]; PLABOR | 28,979.15 | 2562080 | 0 | CHUDAKOV | 1 | 1 | D | 07-024 |  |  | S | EUGENE C |  |  | 11-006 | 11-026 |  | 12-021 |  |  | EJ | 13-015 | PR | ST |  | 13-007 |  |  |  |  | 14-001 |  |  | EJ |  |  |  |  |  |  |  |  |
| 2562450 | Install TOF Sys (Installtn) |  | 17d | 2014-04-08 | 2014-04-30 | 2562480a, 2561165 FS-14d, 2562480 | 64d | 0d | 8/5 M-F w/JLAB Holidays ReBaseline | MECH TECH [220 h]; MECH ENG [16 h]; MECH DES [8 h]; SUPPLIES & MATERIALS | 13,253.8 | 2562450 | 0 | CHUDAKOV | 1 | 1 | D | 07-024 |  | APP | S | EUGENE C |  |  | 11-006 | 11-026 |  |  | 12-054 |  | EJ | 13-015 | PR | ST | 09-014 | 13-007 |  |  |  |  | 14-001 |  |  | EJ |  |  |  |  | 12-049 |  |  |  |
| 2562630 | Install nitrogen lines in hall D |  | 26d | 2014-04-11 | 2014-05-16 | 2562810 FS+63d | 94d |  | 8/5 M-F w/JLAB Holidays ReBaseline | MECH TECH [289.2 h] | 13,684.94 | 2562630 | 0 | CHUDAKOV | 1 | 1 | D |  |  |  | S | EUGENE C |  |  | 11-006 | 11-026 |  | 12-021 |  |  | PE | 13-015 | PR | ST |  | 13-007 |  |  |  |  | 14-001 |  |  |  | 1 |  |  |  |  |  |  |  |
| 2562095 | Cables - Install on Trays Detector to Racks Tagger |  | 10d | 2014-04-17 | 2014-04-30 | 2562080 FS+1d, 2562065, 2562085, 2562090, 2562085a | 67d | 0d | 8/5 M-F w/JLAB Holidays ReBaseline | SCIENTIST; ELEC TECH [80 h] | 3,759.2 | 2562095 | 0 | CHUDAKOV | 1 | 1 | D | 07-024 |  |  | U | EUGENE C |  |  | 11-006 | 11-026 |  | 12-021 |  |  | PE | 13-015 | PR |  | 09-014 | 13-007 |  |  |  |  | 14-001 |  |  |  |  |  |  |  |  |  |  |  |
| 2562515 | Crates - Loaded (VME64x VXS HV LV) Install Hall Tagger |  | 5d | 2014-04-21 | 2014-04-25 | 2548025, 2548025a, 9-140M FS+134d | 99d | 32d | 8/5 M-F w/JLAB Holidays ReBaseline | ELEC TECH [80 h] | 3,759.2 | 2562515 | 0 | CHUDAKOV | 1 | 1 | D | 07-024 |  |  | U | EUGENE C |  |  | 11-006 | 11-026 |  | 12-021 | 12-054 |  | PE | 13-015 | PR |  | 09-014 |  |  |  |  |  | 14-001 | 10-042 |  |  | 1 |  |  |  |  |  |  |  |
| 2562455 | Cables - Install on Trays Detector to Racks TOF |  | 5d | 2014-05-01 | 2014-05-07 | 2547190a, 2547200, 2562035M, 2547200a, 2547190, 2562450 | 64d | 0d | 8/5 M-F w/JLAB Holidays ReBaseline | SCIENTIST; ELEC TECH [160 h] | 7,518.4 | 2562455 | 0 | CHUDAKOV | 1 | 1 | D | 07-024 |  |  | U | EUGENE C |  |  | 11-006 | 11-026 |  |  | 12-054 |  | PE | 13-015 | PR |  | 09-014 | 13-007 |  |  |  |  | 14-001 |  |  |  |  |  |  |  | 12-049 |  |  |  |
| 2562900 | Preparing OSP ESAD documentation Rediness Review for October 14 Beam Run |  | 93d | 2014-05-06 | 2014-09-16 | 2562890 FS-104d | 10d |  | 8/5 M-F w/JLAB Holidays ReBaseline | MECH TECH [40 h]; MECH ENG [240 h]; SR STAFF [400 h]; SCIENTIST [360 h]; MECH DES [120 h]; ELEC ENG [40 h]; SUPPLIES & MATERIALS | 106,747.35 | 2562900 | 0 | CHUDAKOV | 1 | 1 | D |  |  |  | S | EUGENE C |  |  |  |  |  |  |  |  | PE | 13-015 | PR |  |  | 13-007 |  |  |  |  | 14-001 |  |  | PE |  |  |  |  |  |  |  |  |

Notes:
- 2562478: Steps: Install CW control system; Setup DAQ system; Check dark room environment control; Check scope signals to verify correct assignment of signal and control signals; Start data taking with a few boards in one crate and verify operation; Check that data is recorded with a single full crate; Check multi-crate operation; Setup LED trigger; Verify all channels are operational by pulsing various LED combinations; Check data with LED trigger; Setup self-trigger on individual block; Verify trigger system is operational in single self-trigger mode; Setup of self-trigger OR of multiple modules; Verify trigger system is operational for all modules in self-trigger mode; Setup cosmic-ray trigger; Check consistency of patterns of cosmic-ray tracks in fADCs
- 2562482: Steps: Monitoring data with LEDs; Cosmic-ray data; Study feature extraction and sparcification; Setup test and analyze FCAL data
- 2562745: Steps: chilled water heat exchanger; fan system; duct work; hardware
- 2562770: Steps: Eng concept/develop requirements; 3D model; Make Drawings; Structural analysis; Check Drawings; Release drawing package; Issue procurment
- 2562875: Steps: Eng concept/develop requirements; 3D model; Make Drawings; systeml analysis; Check Drawings; Release drawing package; Issue procurment
- 2562625: Steps: attach unistrut and hangers for upstream conduit; install upstream conduit; pull cables for upstream area; install outlets and test; attach unistrut and hangers for solenoid platform conduit; install solenoid platform conduit; pull cables for solenoid platform; install outlets and test1; attach unistrut and hangers for FCAL platform conduit; install FCAL platform conduit; pull cables for FCAL platform; install outlets and test2
- 2562840: Steps: install conduit; pull cable; install outlets; connect to equipment and test
- 2562278: Steps: Setup DAQ configuration; Check scope signals to verify correct assignment of signal and control signals; Start data taking with a few boards in one crate and verify operation; Check that data is correctly recorded with a single full crate; Check multi-crate operation; Check data with LED trigger; Check consistency between signals in ADC vs TDC; upstream vs downtream; Verify trigger system is operational in single self-trigger mode; Verify trigger system is operational for all modules in self-trigger mode; Check consistency of patterns of cosmic-ray tracks in fADCs and TDCs; upstream and downstream
- 2562180: Steps: install beamtube and valves; leak check beamline
- 2562870: Steps: install conduit; pull cables; mount fixtures and connect power
- 2562085a: Steps: __position_on_floor
- 2562181b: Steps: install beamtube and valves; leak check beamline
- 2562478a: Steps: Install CW control system; Setup DAQ system; Check dark room environment control; Check scope signals to verify correct assignment of signal and control signals; Start data taking with a few boards in one crate and verify operation; Check that data is recorded with a single full crate; Check multi-crate operation; Setup LED trigger; Verify all channels are operational by pulsing various LED combinations; Check data with LED trigger; Setup self-trigger on individual block; Verify trigger system is operational in single self-trigger mode; Setup of self-trigger OR of multiple modules; Verify trigger system is operational for all modules in self-trigger mode; Setup cosmic-ray trigger; Check consistency of patterns of cosmic-ray tracks in fADCs
- 2562482a: Steps: Monitoring data with LEDs; Cosmic-ray data; Study feature extraction and sparcification; Setup test and analyze FCAL data
- 2562060: Steps: final align quad; align photon beamline
- 2562855: Steps: attach unistrut and hangers for conduit in counting house; install counting house conduit from UPS; attach unistrut and hangers for conduit in hall; mount UPS panel in hall; install conduit in hall; pull cables; connect to equipment and test
- 2562635: Steps: attach unistrut and hangers for air lines; install compressor;pipe and valves from outdoor gas hut to north wall; install pipe and valves from north wall to upstream and solenoid platform; install pipe and valves from upstream platform to collimator cave; Pressure test and leak check; inspection of welds/brazes
- 2562860: Steps: mark floor for stand locations; Drill floor and install anchors; set stands; prelim align stands; Install tagger thin window; install beamtube and valves; leak check beamline
- 2562065: Steps: install conduit from panels to 4 tagger racks; pull cable; install outlets in racks; Test all circuits
- 2562750: Steps: install chilled water heat exchanger; install fan system; install duct work; test/adjust system
- 2562281: Steps: Room temp: Monitoring data with LEDs; Room temp: Cosmic-ray data; Room temp: Study feature extraction and sparcification; Room temp:Setup test and analyze BCAL data; Low temp: Monitoring data with LEDs; Low temp: Cosmic-ray data; Low temp: Study feature extraction and sparcification; Low temp:Setup test and analyze BCAL data
- 2562216: Steps: install field map system; Fiducialize probe locations; Program and Test systems; Power magnet andcalibrate probes; map field
- 2562170: Steps: drill/tap platform/wall; attach supports to stand/wall; install device; Survey and align (initial); check profiler operation
- 2562300: Steps: mount CDC on cart; fiducialize CDC; install cooling ducts; insert into BCL; final align
- 2562165: Steps: install support structure; survey and align support structure; install detectors; align detectors; hook up SiPm cooling; install dark box; Test mechanical systems
- 2562303: Steps: assemble system; install in place; fiducialize system
- 2562280: Steps: Verify setting of SiPM bias; Check temperature monitoring system; Check chiller readback and monitoring; Setup LED trigger; Verify all channels are operational by pulsing separate LED strings with single bias on; Setup self-trigger of single module; Setup of self-trigger OR of multiple modules; Setup cosmic-ray trigger consisting of (OR top)AND(OR bottom) counters
- 2562780: Steps: Assemble commissioning target; fiducialize target; Install start counter onto target; fiducialize start counter; hook up start counter system; Test start counter systems; Install and survey target
- 2562080: Steps: install support structure fixed array; install support structure microscope; survey and align fixed array structure; survey and align microscope support; install fixed counters; align fixed counters; install microscope; align microscope; hook up and test microscope cooling chiller; install microscope shielding; program microscope adjustment table; Test mechanical systems
- 2562450: Steps: Bring TOF from assy area to hall; install support frame and rails onto FCAL platform frame; Survey support location; install TOF onto rails/support; Check alignment
- 2562630: Steps: attach unistrut and hangers for nitrogen line; install pipe and valves from dewar to north wall; install pipe and valves from north wall to solenoid platform; Pressure test and leak check; inspection of welds/brazes

| ID | WBS | Activity | Type | Duration | Start | Finish | Predecessors | Complete | Planned start | Planned finish | Total float | Free float | Calendar | Resources | Cost | Actual cost | Original Activity ID Rebaseline | MONTHLY EV COST | RESP - Responsibility | STRT%COMP for CM EVM | FNSH%COMP for CM EVM | HALL D Related Milestones | CR 07-024 | EVMS Reporting Codes | CAM RESPONSIBLE | CR 09-014 | CR 11-006 | CR 11-026 | CR 12-021 | CR 13-007 | BOE Labor | CR 13-015 | Post Rebaseline | CR 14-001 | CR 12-049 | CR 12-054 | 12 GeV 1st level Critical Path | CR 10-042 | CR 09-027 | CR 09-027 Repair | Advance Purchase Plan > 500K | Activities with Steps | BOE Expenses | Calculated Remaining Total Cost | CR 11-004 | CR 11-036 | Remaining Material Cost Based on % Compl | Claimed Material Cost Based on % Complet | Initial Claimed Material Calc | Claimed Material Divider | CR 10-024 | CR 11-001 | ReBaseline Actuals Adjustment |
| --- | --- | --- | --- | --- | --- | --- | --- | --- | --- | --- | --- | --- | --- | --- | --- | --- | --- | --- | --- | --- | --- | --- | --- | --- | --- | --- | --- | --- | --- | --- | --- | --- | --- | --- | --- | --- | --- | --- | --- | --- | --- | --- | --- | --- | --- | --- | --- | --- | --- | --- | --- | --- | --- |
| 2562095a |  | Cables - Route and Connect on Detector Tagger |  | 10d | 2014-05-07 | 2014-05-20 | 2562095 FS+4d |  |  |  | 67d | 0d | 8/5 M-F w/JLAB Holidays ReBaseline | SCIENTIST; ELEC TECH [80 h] | 3,759.2 |  | 2562095a | 0 | CHUDAKOV | 1 | 1 | D | 07-024 | U | EUGENE C | 09-014 | 11-006 | 11-026 | 12-021 | 13-007 | PE | 13-015 | PR | 14-001 |  |  |  |  |  |  |  |  |  |  |  |  |  |  |  |  |  |  |  |
| 2562460 |  | Test TOF Sys (Installtn) |  | 20d | 2014-05-08 | 2014-06-05 | 2562455 |  |  |  | 81d |  | 8/5 M-F w/JLAB Holidays ReBaseline | ELEC ENG [80 h]; ELEC TECH [320 h] | 21,047.2 |  | 2562460 | 0 | CHUDAKOV | 1 | 1 | D | 07-024 | U | EUGENE C | 09-014 | 11-006 | 11-026 |  | 13-007 | EJ | 13-015 | PR | 14-001 | 12-049 | 12-054 |  |  |  |  |  |  |  |  |  |  |  |  |  |  |  |  |  |
| 2562455a |  | Cables - Route and Connect on Detector TOF |  | 5d | 2014-05-15 | 2014-05-21 | 2562455 FS+5d |  |  |  | 64d | 0d | 8/5 M-F w/JLAB Holidays ReBaseline | SCIENTIST; ELEC TECH [160 h] | 7,518.4 |  | 2562455a | 0 | CHUDAKOV | 1 | 1 | D | 07-024 | U | EUGENE C | 09-014 | 11-006 | 11-026 |  | 13-007 | PE | 13-015 | PR | 14-001 | 12-049 | 12-054 |  |  |  |  |  |  |  |  |  |  |  |  |  |  |  |  |  |
| 2562095b |  | Cables - Route on Racks Tagger |  | 5d | 2014-05-21 | 2014-05-28 | 2562095a |  |  |  | 67d | 0d | 8/5 M-F w/JLAB Holidays ReBaseline | ELEC TECH [40 h] | 1,879.6 |  | 2562095b | 0 | CHUDAKOV | 1 | 1 | D | 07-024 | U | EUGENE C | 09-014 | 11-006 | 11-026 | 12-021 | 13-007 | PE | 13-015 | PR | 14-001 |  |  |  |  |  |  |  |  |  |  |  |  |  |  |  |  |  |  |  |
| 2562455b |  | Cables - Route on Racks TOF |  | 5d | 2014-05-22 | 2014-05-29 | 2562455a |  |  |  | 64d | 0d | 8/5 M-F w/JLAB Holidays ReBaseline | SCIENTIST; ELEC TECH [80 h] | 3,759.2 |  | 2562455b | 0 | CHUDAKOV | 1 | 1 | D | 07-024 | U | EUGENE C | 09-014 | 11-006 | 11-026 |  | 13-007 | PE | 13-015 | PR | 14-001 | 12-049 | 12-054 |  |  |  |  |  |  |  |  |  |  |  |  |  |  |  |  |  |
| 2562095c |  | Cables - Connect to Crate Electronics Tagger |  | 10d | 2014-05-29 | 2014-06-11 | 2562095b |  |  |  | 67d | 0d | 8/5 M-F w/JLAB Holidays ReBaseline | ELEC ENG [40 h]; ELEC TECH [40 h] | 4,884.8 |  | 2562095c | 0 | CHUDAKOV | 1 | 1 | D | 07-024 | U | EUGENE C | 09-014 | 11-006 | 11-026 | 12-021 | 13-007 | PE | 13-015 | PR | 14-001 |  |  |  |  |  |  |  |  |  |  |  |  |  |  |  |  |  |  |  |
| 2562455c |  | Cables - Connect to Crate Electronics TOF |  | 2d | 2014-05-30 | 2014-06-02 | 2562455b |  |  |  | 64d | 0d | 8/5 M-F w/JLAB Holidays ReBaseline | ELEC ENG [40 h]; ELEC TECH [40 h] | 4,884.8 |  | 2562455c | 0 | CHUDAKOV | 1 | 1 | D | 07-024 | U | EUGENE C | 09-014 | 11-006 | 11-026 |  | 13-007 | PE | 13-015 | PR | 14-001 | 12-049 | 12-054 |  |  |  |  |  |  |  |  |  |  |  |  |  |  |  |  |  |
| 2562510 |  | Check-out Trigger Electrnc's (Installtn) |  | 39d | 2014-07-10 | 2014-09-03 | 2531125 FS-20d, 2562505 |  |  |  | 19d |  | 8/5 M-F w/JLAB Holidays ReBaseline | ELEC ENG [60 h]; ELEC TECH [60 h] | 7,327.2 |  | 2562510 | 0 | CHUDAKOV | 1 | 1 | D | 07-024 | U | EUGENE C |  | 11-006 | 11-026 | 12-021 |  | EJ | 13-015 | PR | 14-001 |  |  |  |  |  |  |  |  |  |  |  |  |  |  |  |  |  |  |  |
| 2562490 |  | Cables - Install on Trays Detector to Racks Start Counter |  | 2d | 2014-09-03 | 2014-09-04 | 2562485 FS-11d, 2562245 |  |  |  | 8d | 0d | 8/5 M-F w/JLAB Holidays ReBaseline | SCIENTIST; ELEC TECH [80 h] | 3,759.2 |  | 2562490 | 0 | CHUDAKOV | 1 | 1 | D | 07-024 | U | EUGENE C | 09-014 | 11-006 | 11-026 | 12-021 | 13-007 | PE | 13-015 | PR | 14-001 |  | 12-054 | 1 | 10-042 |  |  |  |  |  |  |  |  |  |  |  |  |  |  |  |
| 2562485 |  | Install Start Counter Onto LH Target (Installtn) |  | 10d | 2014-09-04 | 2014-09-17 | 2552006, 2552007, 2552040, 25213005, 282462000 |  |  |  | 0d |  | 8/5 M-F w/JLAB Holidays ReBaseline | MECH ENG [12 h]; MECH TECH [104 h]; SCIENTIST [160 h] | 17,846.12 |  | 2562485 | 0 | CHUDAKOV | 1 | 1 | D | 07-024 | S | EUGENE C | 09-014 | 11-006 | 11-026 | 12-021 | 13-007 | PE | 13-015 | PR | 14-001 |  | 12-054 | 1 | 10-042 | 09-027 | 09-027 |  |  |  |  |  |  |  |  |  |  |  |  |  |
| 2562091M |  | Tagger Ready For Beam (Installtn) | milestone | 0d | 2014-09-04 | 2014-09-04 | 2562061, 2553195, 2562098, 282453000, 2562060 |  |  |  | 18d |  | 8/5 M-F w/JLAB Holidays ReBaseline |  |  |  | 2562091M | 0 | CHUDAKOV | 1 | 1 | D | 07-024 | M | EUGENE C | 09-014 | 11-006 | 11-026 | 12-021 | 13-007 |  | 13-015 | PR |  |  |  |  |  |  |  |  |  |  |  |  |  |  |  |  |  |  |  |  |
| 2562490a |  | Cables - Route and Connect on Detector Start Counter |  | 2d | 2014-09-05 | 2014-09-08 | 2562490 |  |  |  | 30d | 0d | 8/5 M-F w/JLAB Holidays ReBaseline | SCIENTIST; ELEC TECH [80 h] | 3,759.2 |  | 2562490a | 0 | CHUDAKOV | 1 | 1 | D | 07-024 | U | EUGENE C | 09-014 | 11-006 | 11-026 | 12-021 | 13-007 | PE | 13-015 | PR | 14-001 |  | 12-054 |  |  |  |  |  |  |  |  |  |  |  |  |  |  |  |  |  |
| 2562495 |  | Test Start Counter (Installtn) |  | 10d | 2014-09-05 | 2014-09-18 | 2562490 |  |  |  | 8d |  | 8/5 M-F w/JLAB Holidays ReBaseline | ELEC ENG [8 h]; ELEC TECH [200 h] | 9,999.04 |  | 2562495 | 0 | CHUDAKOV | 1 | 1 | D | 07-024 | H | EUGENE C | 09-014 | 11-006 | 11-026 | 12-021 | 13-007 | EJ | 13-015 | PR | 14-001 |  | 12-054 | 1 | 10-042 |  |  |  |  |  |  |  |  |  |  |  |  |  |  |  |
| 2562490b |  | Cables - Route on Racks Start Counter |  | 2d | 2014-09-09 | 2014-09-10 | 2562490a |  |  |  | 30d | 0d | 8/5 M-F w/JLAB Holidays ReBaseline | ELEC TECH [40 h] | 1,879.6 |  | 2562490b | 0 | CHUDAKOV | 1 | 1 | D | 07-024 | U | EUGENE C | 09-014 | 11-006 | 11-026 | 12-021 | 13-007 | PE | 13-015 | PR | 14-001 |  | 12-054 |  |  |  |  |  |  |  |  |  |  |  |  |  |  |  |  |  |
| 2562490c |  | Cables - Connect to Crate Electronics Start Counter |  | 2d | 2014-09-11 | 2014-09-12 | 2562490b |  |  |  | 30d | 0d | 8/5 M-F w/JLAB Holidays ReBaseline | ELEC ENG [40 h]; ELEC TECH [40 h] | 4,884.8 |  | 2562490c | 0 | CHUDAKOV | 1 | 1 | D | 07-024 | U | EUGENE C | 09-014 | 11-006 | 11-026 | 12-021 | 13-007 | PE | 13-015 | PR | 14-001 |  | 12-054 |  |  |  |  |  |  |  |  |  |  |  |  |  |  |  |  |  |
| 2562175 |  | Install Hydrogen Target and Start Counter Inside Detector (Installtn) |  | 10d | 2014-09-17 | 2014-09-30 | 282446040, 2546567, 2552040, 25213025, 282446030, 282446030a, 282446035a, 2562485 FS-1d, 282446040a, 282446035, 2546567a |  |  |  | 0d |  | 8/5 M-F w/JLAB Holidays ReBaseline | SUPPLIES & MATERIALS; MECH TECH [576 h]; MECH ENG [12 h] | 34,343.76 |  | 2562175 | 0 | CHUDAKOV | 1 | 1 | D | 07-024 | S | EUGENE C | 09-014 | 11-006 | 11-026 | 12-021 | 13-007 | PE | 13-015 | PR | 14-001 |  | 12-054 |  | 10-042 | 09-027 | 09-027 | APP | ST | EJ |  |  |  |  |  |  |  |  |  |  |
|  | 3 | **1.5.6.3 CRYOGENICS** |  |  | 2010-05-03 | 2013-08-30 |  |  |  |  |  |  |  |  |  |  |  |  |  |  |  |  |  |  |  |  |  |  |  |  |  |  |  |  |  |  |  |  |  |  |  |  |  |  |  |  |  |  |  |  |  |  |  |
| 1563005 |  | Release U-tube Fabrication Drawings (CRYOGENICS) |  | 315d | 2010-05-03 A | 2011-08-05 A | 9-100M FS+60d | 100% |  |  |  |  |  | MECH ENG [40 h]; MECH TECH [40 h] | 4,394.63 | 4,394.63 |  | 4303.6 | CHUDAKOV | 1 | 1 | D | 07-024 | H | EUGENE C |  | 11-006 |  |  |  |  |  |  |  |  |  |  | 10-042 |  |  |  |  |  | 0 | 11-004 | 11-036 |  |  |  |  |  |  |  |
| 1563010 |  | Release Warm Gas Plumbing Fabrication Drawings (CRYOGENICS) (Frozen per CR11-036) |  | 316d | 2010-05-03 A | 2011-08-08 A | 9-100M FS+60d | 100% |  |  |  |  |  | MECH ENG [40 h]; MECH DES [80 h]; MECH TECH [320 h] | 20,025.22 | 20,025.22 |  | 19610 | CHUDAKOV | 1 | 1 | D | 07-024 | H | EUGENE C |  | 11-006 |  |  |  |  |  |  |  |  |  |  | 10-042 |  |  |  |  |  | 0 | 11-004 | 11-036 |  |  |  |  |  |  |  |
| 1563015 |  | Release Transfer Line Fabrication Drawings (CRYOGENICS) (Frozen per CR11-036) |  | 316d | 2010-05-03 A | 2011-08-08 A | 9-100M FS+60d | 100% |  |  |  |  |  | MECH DES [360 h]; MECH ENG [40 h]; MECH TECH [160 h] | 26,140.55 | 26,140.55 |  | 25598.8 | CHUDAKOV | 1 | 1 | D | 07-024 | H | EUGENE C |  | 11-006 |  |  |  |  |  |  |  |  |  |  | 10-042 |  |  |  |  |  | 0 | 11-004 | 11-036 |  |  |  |  |  |  |  |
| 1563006 |  | Proc U-tubes (CRYOGENICS) (Frozen per CR11-036) |  | 6d | 2011-08-01 A | 2011-08-08 A | 1563005 FS-6d, 9-120M FS+80d | 100% |  |  |  |  |  | PROCUREMENT>$50K 69 NO ESCALATION FY11 | 17,580.56 |  |  | 17580.56 | CHUDAKOV | 1 | 1 | D |  | D | EUGENE C |  | 11-006 |  |  |  |  |  |  |  |  |  |  | 10-042 |  |  |  |  |  | 0 | 11-004 | 11-036 | 0 | 17580.56 | 1758056 | 100 |  |  |  |
| 1563011 |  | Proc Warm Gas Plumbing (CRYOGENICS) (Frozen per CR11-036) |  | 6d | 2011-08-01 A | 2011-08-08 A | 1563010 FS-17d | 100% |  |  |  |  |  | PROCUREMENT>$50K 69 NO ESCALATION FY11 | 17,580.56 |  |  | 17580.56 | CHUDAKOV | 1 | 1 | D |  | D | EUGENE C |  | 11-006 |  |  |  |  |  |  |  |  |  |  | 10-042 |  |  |  |  |  | 0 | 11-004 | 11-036 | 0 | 17580.56 | 1758056 | 100 |  |  |  |
| 1563016 |  | Proc Transfer Line (CRYOGENICS) (Frozen per CR11-036) |  | 6d | 2011-08-01 A | 2011-08-08 A | 1563015 FS-25d | 100% |  |  |  |  |  | PROCUREMENT>$50K 69 NO ESCALATION FY11 | 68,124.69 |  |  | 68124.69 | CHUDAKOV | 1 | 1 | D |  | D | EUGENE C |  | 11-006 |  |  |  |  |  |  |  |  |  |  | 10-042 |  |  |  |  |  | 0 | 11-004 | 11-036 | 0 | 68124.69 | 6812469 | 100 |  |  |  |
| 1563017 |  | Proc Cryo Distribution for Magnet (Labor) (CRYOGENICS) FY10 (Frozen per CR11-036) |  | 6d | 2011-08-01 A | 2011-08-08 A | 1563015 | 100% |  |  |  |  |  | MECH ENG [160 h] | 10,872 | 10,872 |  | 10536 | CHUDAKOV | 1 | 1 | D |  | D | EUGENE C |  | 11-006 |  |  |  |  |  |  |  |  |  |  |  |  |  |  |  |  | 0 | 11-004 | 11-036 |  |  |  |  | 10-024 | 11-001 |  |
| 1563017a |  | Proc Cryo Distribution for Magnet (Labor) (CRYOGENICS) FY11 (Frozen per CR11-036) |  | 6d | 2011-08-01 A | 2011-08-08 A | 1563017 | 100% |  |  |  |  |  | MECH ENG [240 h] | 16,308 | 16,308 |  | 16308 | CHUDAKOV | 1 | 1 | D |  | D | EUGENE C |  | 11-006 |  |  |  |  |  |  |  |  |  |  |  |  |  |  |  |  | 0 | 11-004 | 11-036 |  |  |  |  | 10-024 | 11-001 |  |
| 1563020 |  | Release Cryogenic Instrumentation Drawings (CRYOGENICS) (Frozen per CR11-036) |  | 6d | 2011-08-01 A | 2011-08-08 A | 9-100M FS+60d | 100% |  |  |  |  |  | MECH ENG [80 h]; MECH DES [120 h]; MECH TECH [320 h] | 24,820 | 24,820 |  | 24053.6 | CHUDAKOV | 1 | 1 | D | 07-024 | H | EUGENE C |  | 11-006 |  |  |  |  |  |  |  |  |  |  | 10-042 |  |  |  |  |  | 0 | 11-004 | 11-036 |  |  |  |  |  |  |  |
| 1563025 |  | Proc Cryogenic Instrumentation (CRYOGENICS) (Frozen per CR11-036) |  | 6d | 2011-08-01 A | 2011-08-08 A | 1563020 FS+15d | 100% |  |  |  |  |  | PROCUREMENT<$50K 60 NO ESCALATION FY11 | 5,493.93 |  |  | 5493.93 | CHUDAKOV | 1 | 1 | D | 07-024 | D | EUGENE C |  | 11-006 |  |  |  |  |  |  |  |  |  |  | 10-042 |  |  |  |  |  | 0 | 11-004 | 11-036 | 0 | 5493.93 | 549393 | 100 |  |  |  |
| 1563030 |  | Reverse Entry per CR11-036 |  | 5d | 2011-08-01 A | 2011-08-05 A | 9-110M FS+204d | 100% |  |  |  |  |  | MECH TECH [-580 h]; PROCUREMENT<$50K 60; PROCUREMENT>$50K 69; MECH DES [-340 h]; MECH ENG [-540 h] | -186,324.54 | -77,544.8 |  |  | CHUDAKOV | 1 | 1 | D | 07-024 | H | EUGENE C |  | 11-006 |  |  |  |  |  |  |  |  |  |  | 10-042 |  |  |  |  |  |  | 11-004 | 11-036 |  |  |  | 100 |  |  |  |
| 1563035 |  | Re-Baseline Actuals Adjustment |  | 1d | 2013-08-30 A | 2013-08-30 A |  | 100% | 2013-09-03 | 2013-09-03 |  |  |  | PROCUREMENT>$50K 69 NO ESCALATION | 128,274.73 |  |  | 128274.73 |  |  |  |  |  |  |  |  |  |  |  |  |  |  |  |  |  |  |  |  |  |  |  |  |  |  |  |  | 0 | 128274.73 | 12827473 | 100 |  |  | ADJ |

Notes:
- 2562175: Explanation: IPL from 6 GeV 551210 / Steps: fiducialize start counter; fiducialize target; install SC on to target; hook up target gas systems; hook up target cryo system; Test target/SC systems
