# October 13 Progress 12 GeV CR13-015,14-001

Schedule from Primavera P6, 2004-03-31 to 2017-12-19, data date 2013-10-31, costs in USD, A marks actual dates.
CHANGE REQUESTS INCLUDED / FY07 002, 003, 006, 007, 008, 010, 005, 009, 014, 012, 15, / 17, 18, 29-33 / FY08 / 001,002,003,005,004,011,014,013,009,016,018,017,019,020,24N/C,23,10,25,21,22,27,28,26,31,29,32,33,34,35, / 36,37,38,39,40,41,42,44,43,45,46,48,49,51,50,52,54,55,56, 57 ,58,59,60 / FY09 003, 002, 004, 005, 007, 008, 009, 010, 011, 012, / 14A-G,16,17,15,23, / 26,22,24,31,35,34,33,32,27,28,36,30,37,38,43,40,46,41,47,48,44,43A,49,52,51,39,42,53,64,66,61,71,70,67,63,01VA / FY10 001A-E,002, 005 ,003,004, / 008,007,010,011,012,18,23,12A,035,036,22,32,33,34,20,21,29,37,24,26,9,19,30,27,41,38,40,43,39,44,16,45,25,28,31, / 14,46,48,52,53,54,56,55,42,57,47,17,15,62,59,64,66,61,71,70,67,63,VA1,60,65,73 / FY11 / 001,002,007,003,010,016,011,014,15,19,09,17,18,12,13,20,06,08,22,23,VA2,VA3,26,24,27,31,28,30,29,38,25,32,37,46,47,35,40,43,42,44,41,22a,49,52,51,005,48,39,36,55,57,54,53 / FY12 001-A&D, / 005,002,003,007,010,009,011,008,012,014,015,016,17,13,22,25,18,23,21,26,24,29,28,27,29A,34,37,38,35,36,32,39,42,44,45,43,50,46,47,53,51,54,49,55 / FY13 001D,003,008,009,002,004,005,12,06,11,14,15,16 / This project is to be used to develop the new DOE guidance schedule / Mark Wiseman's PED corrections have been made - RKC / Implemented IPLs with 6 GeV / Hardening Schedule- 27 August 08 PMK
Must finish by 2017-09-30

| ID | WBS | Activity | Type | Duration | Start | Finish | Predecessors | Complete | Planned start | Planned finish | Resources | Cost | Actual cost | Calculated Remaining Total Cost | MONTHLY EV COST | RESP - Responsibility | STRT%COMP for CM EVM | FNSH%COMP for CM EVM | HALL D Related Milestones | EVMS Reporting Codes | CAM RESPONSIBLE | CR 11-037 | CR 12-021 | LOE % Pre Calc | LOE % | LOE Divider | LOE Multiplier | Claimed Material Divider | ReBaseline Actuals Adjustment | Milestone Level | CR 10-028 | CR 11-055 | CR 12-029 | Remaining Material Cost Based on % Compl | Claimed Material Cost Based on % Complet | Initial Claimed Material Calc | Advance Purchase Plan > 500K | CR 08-014 | CR 08-016 | 12 GEV MAJOR PROCUREMENT CATAGORY | CR 09-012 | CR 10-032 | CR 10-045 | CR 07-029 | Activities with Steps | CR 11-001 |
| --- | --- | --- | --- | --- | --- | --- | --- | --- | --- | --- | --- | --- | --- | --- | --- | --- | --- | --- | --- | --- | --- | --- | --- | --- | --- | --- | --- | --- | --- | --- | --- | --- | --- | --- | --- | --- | --- | --- | --- | --- | --- | --- | --- | --- | --- | --- |
|  | 7 | **1.5.7 SPARE HALL D SOLENOID** |  |  | 2011-07-01 | 2013-08-30 |  |  |  |  |  |  |  |  |  |  |  |  |  |  |  |  |  |  |  |  |  |  |  |  |  |  |  |  |  |  |  |  |  |  |  |  |  |  |  |  |
| 157005 |  | Spare Hall D Solenoid Procurement Process FY11 Labor |  | 64d | 2011-07-01 A | 2011-09-30 A | 9-110M FS+184d | 100% |  |  | SR STAFF [256 h] | 28,034.56 | 28,034.56 | 0 | 28034.56 | CHUDAKOV | 1 | 1 | D | H | EUGENE C | 11-037 | 12-021F |  |  |  |  |  |  |  |  |  |  |  |  |  |  |  |  |  |  |  |  |  |  |  |
| 157010 |  | Spare Hall D Solenoid Procurement Process FY12 Labor |  | 87d | 2011-10-03 A | 2012-02-13 A | 157005 | 100% |  |  | SR STAFF [232 h] | 26,216 | 26,216 | 0 | 26216 | CHUDAKOV | 1 | 1 | D | H | EUGENE C | 11-037 | 12-021F |  |  |  |  |  |  |  |  |  |  |  |  |  |  |  |  |  |  |  |  |  |  |  |
| 157020 |  | Spare Hall D Solenoid FY12 Oversight Labor |  | 22.98d | 2012-01-03 A | 2012-02-03 A | 157010 FS-30d | 100% |  |  | SR STAFF [80 h] | 9,039.98 | 9,040 | 0 | 9040 | CHUDAKOV | 1 | 1 | D | E | EUGENE C | 11-037 | 12-021 | 89.41798941 | 10.58201058 | 100 | 100 |  |  |  |  |  |  |  |  |  |  |  |  |  |  |  |  |  |  |  |
| 157030 |  | Spare Hall D Solenoid FY13 Oversight Labor |  | 20d | 2013-08-30 A | 2013-08-30 A | 157020, 9-130M FS+184d | 100% | 2013-09-03 | 2013-09-30 | SR STAFF [464.75 h] | 54,189.85 | 54,189.85 | 78821.6 | 54189.85 | CHUDAKOV | 1 | 1 | D | E | EUGENE C | 11-037 | 12-021 | 100 | 0 | 100 | 100 |  |  |  |  |  |  |  |  |  |  |  |  |  |  |  |  |  |  |  |
| 157045 |  | Re-Baseline Actuals Adjustment |  | 1d | 2013-08-30 A | 2013-08-30 A |  | 100% | 2013-09-03 | 2013-09-03 | PROCUREMENT>$50K 69 NO ESCALATION | -63,176.3 |  |  |  |  |  |  |  |  |  |  |  |  |  |  |  | 100 | ADJ |  |  |  |  |  |  |  |  |  |  |  |  |  |  |  |  |  |
|  | 6 | **1.6 CONVENTIONAL FACILITIES** |  |  | 2007-10-01 | 2015-10-02 |  |  |  |  |  |  |  |  |  |  |  |  |  |  |  |  |  |  |  |  |  |  |  |  |  |  |  |  |  |  |  |  |  |  |  |  |  |  |  |  |
|  | 1 | **1.6.1 ACCELERATOR** |  |  | 2009-10-29 | 2015-10-02 |  |  |  |  |  |  |  |  |  |  |  |  |  |  |  |  |  |  |  |  |  |  |  |  |  |  |  |  |  |  |  |  |  |  |  |  |  |  |  |  |
|  | 1 | **1.6.1.1 BUILDINGS** |  |  | 2009-10-29 | 2015-10-02 |  |  |  |  |  |  |  |  |  |  |  |  |  |  |  |  |  |  |  |  |  |  |  |  |  |  |  |  |  |  |  |  |  |  |  |  |  |  |  |  |
|  | 1 | **1.6.1.1.1 NORTH & SOUTH ACCESS BUILDING ADDITIONS** |  |  | 2009-10-29 | 2013-08-30 |  |  |  |  |  |  |  |  |  |  |  |  |  |  |  |  |  |  |  |  |  |  |  |  |  |  |  |  |  |  |  |  |  |  |  |  |  |  |  |  |
| 16111000M |  | N&S Access Addition Post Solicitation | milestone | 0d | 2009-10-29 A | 2009-10-29 A | 9-100M, 1241035M | 100% | 2009-11-02 | 2009-11-02 |  |  |  |  | 0 | WHITLATCH C | 1 | 1 |  | M | REBECCA Y |  |  |  |  |  |  |  |  | 6 | 10-028 | 11-055 |  |  |  |  |  |  |  |  |  |  |  |  |  |  |
| 16111005 |  | N&S Access Addition Award Contract |  | 47d | 2009-10-29 A | 2010-01-13 A | 16111000M FS-100d | 100% |  |  | PLANT ENG [80 h] | 5,277.6 | 5,277.6 | 0 | 5277.6 | WHITLATCH C | 1 | 1 |  | H | REBECCA Y |  |  |  |  |  |  |  |  |  | 10-028 | 11-055 | 12-029F |  |  |  |  |  |  |  |  |  |  |  |  |  |
| 16111010 |  | N&S Access Constrctn Contract April Progress Payment |  | 72d | 2010-01-20 A | 2010-04-30 A | 16111005 | 100% |  |  | PROCUREMENT<$50K 60 NO ESCALATION; PROCUREMENT>$50K 69 NO ESCALATION | 81,143 |  | 0 | 81143 | WHITLATCH C | 1 | 1 |  | C | REBECCA Y |  |  |  |  |  |  | 100 |  |  | 10-028 | 11-055 | 12-029F | 0 | 81143 | 8114300 | APP | 08-014 | 08-016 | 6111 | 09-012 | 10-032 | 10-045 |  |  |  |
| 16111010A |  | N&S Access Constrctn Contract May Progress Payment |  | 114d | 2010-01-20 A | 2010-06-30 A | 16111010 FS-72d | 100% |  |  | PROCUREMENT>$50K 69 NO ESCALATION | 190,355 |  | 0 | 190355 | WHITLATCH C | 1 | 1 |  | C | REBECCA Y |  |  |  |  |  |  | 100 |  |  | 10-028 | 11-055 | 12-029F | 0 | 190355 | 19035500 | APP |  |  | 6111 |  |  | 10-045 |  |  |  |
| 16111010B |  | N&S Access Constrctn Contract June Progress Payment |  | 114d | 2010-01-20 A | 2010-06-30 A | 16111010A FS-92d | 100% |  |  | PROCUREMENT>$50K 69 NO ESCALATION | 206,252 |  | 0 | 206252 | WHITLATCH C | 1 | 1 |  | C | REBECCA Y |  |  |  |  |  |  | 100 |  |  | 10-028 | 11-055 | 12-029F | 0 | 206252 | 20625200 | APP |  |  | 6111 |  |  | 10-045 |  |  |  |
| 16111010C |  | N&S Access Constrctn Contract July Progress Payment |  | 133d | 2010-01-20 A | 2010-07-28 A | 16111010B FS-114d | 100% |  |  | PROCUREMENT>$50K 69 NO ESCALATION | 565,312 |  | 0 | 565312 | WHITLATCH C | 1 | 1 |  | C | REBECCA Y |  |  |  |  |  |  | 100 |  |  | 10-028 | 11-055 | 12-029F | 0 | 565312 | 56531200 | APP |  |  | 6111 |  |  | 10-045 |  |  |  |
| 16111010D |  | N&S Access Constrctn Contract August Progress Payment |  | 157d | 2010-01-20 A | 2010-08-31 A | 16111010C FS-135d | 100% |  |  | PROCUREMENT>$50K 69 NO ESCALATION | 181,930 |  | 0 | 181930 | WHITLATCH C | 1 | 1 |  | C | REBECCA Y |  |  |  |  |  |  | 100 |  |  | 10-028 | 11-055 | 12-029F | 0 | 181930 | 18193000 | APP |  |  | 6111 |  |  | 10-045 |  |  |  |
| 16111010G |  | N&S Access Constrctn Contract September Progress Payment |  | 157d | 2010-01-20 A | 2010-08-31 A | 16111010D FS-157d | 100% |  |  | PROCUREMENT>$50K 69 NO ESCALATION | 110,544 |  | 0 | 110544 | WHITLATCH C | 1 | 1 |  | C | REBECCA Y |  |  |  |  |  |  | 100 |  |  | 10-028 | 11-055 | 12-029F | 0 | 110544 | 11054400 | APP |  |  | 6111 |  |  | 10-045 |  |  |  |
| 16111010H |  | N&S Access Constrctn Contract October Progress Payment |  | 157d | 2010-01-20 A | 2010-08-31 A | 16111010G FS-178d | 100% |  |  | PROCUREMENT>$50K 69 NO ESCALATION | 49,511 |  | 0 | 49511 | WHITLATCH C | 1 | 1 |  | C | REBECCA Y |  |  |  |  |  |  | 100 |  |  | 10-028 | 11-055 | 12-029F | 0 | 49511 | 4951100 | APP |  |  | 6111 |  |  | 10-045 |  |  |  |
| 16111010J |  | N&S Access Constrctn Contract November Progress Payment |  | 178d | 2010-01-20 A | 2010-09-30 A | 16111010H FS-199d | 100% |  |  | PROCUREMENT>$50K 69 NO ESCALATION | 14,655 |  | 0 | 14655 | WHITLATCH C | 1 | 1 |  | C | REBECCA Y |  |  |  |  |  |  | 100 |  |  | 10-028 | 11-055 | 12-029F | 0 | 14655 | 1465500 | APP |  |  | 6111 |  |  | 10-045 |  |  |  |
| 16111010K |  | N&S Access Constrctn Contract December Progress Payment |  | 178d | 2010-01-20 A | 2010-09-30 A | 16111010J FS-219d | 100% |  |  | PROCUREMENT>$50K 69 NO ESCALATION | 11,941 |  | 0 | 11941 | WHITLATCH C | 1 | 1 |  | C | REBECCA Y |  |  |  |  |  |  | 100 |  |  | 10-028 | 11-055 | 12-029F | 0 | 11941 | 1194100 | APP |  |  | 6111 |  |  | 10-045 |  |  |  |
| 16111010N |  | N&S Access Constrctn Contract January Progress Payment |  | 178d | 2010-01-20 A | 2010-09-30 A | 16111010K FS-236d | 100% |  |  | PROCUREMENT>$50K 69 NO ESCALATION | 367 |  | 0 | 367 | WHITLATCH C | 1 | 1 |  | C | REBECCA Y |  |  |  |  |  |  | 100 |  |  | 10-028 | 11-055 | 12-029F | 0 | 367 | 36700 | APP |  |  | 6111 |  |  | 10-045 |  |  |  |
| 16111012 |  | N&S Access Constrctn Contract Modifications |  | 178d | 2010-01-20 A | 2010-09-30 A | 16111005 FS+10d | 100% |  |  | PROCUREMENT>$50K 69 NO ESCALATION | 70,600.5 |  | 0 | 70600.5 | WHITLATCH C | 1 | 1 |  | C | REBECCA Y |  |  |  |  |  |  | 100 |  |  | 10-028 | 11-055 | 12-029F | 0 | 70600.5 | 7060050 | APP | 08-014 | 08-016 | 6111 | 09-012 | 10-032 |  |  |  |  |
| 16111020 |  | N&S Access Addition Constrctn Mngmnt FY10 |  | 178d | 2010-01-20 A | 2010-09-30 A | 16111005 FS+10d | 100% |  |  | PLANT ENG [813.01 h]; OFFICE [344.91 h]; ELEC ENG [49.27 h]; MECH ENG [24.64 h]; MECH TECH [862.28 h]; MECH DES [24.64 h] | 104,875.25 | 104,875.25 | 0 | 104875.2545 | WHITLATCH C | 1 | 1 |  | C | REBECCA Y |  |  |  |  |  |  |  |  |  | 10-028 | 11-055 | 12-029F |  |  |  |  |  |  |  |  | 10-032 |  | 07-029 | NB | 11-001 |
| 16111020a |  | N&S Access Addition Constrctn Mngmnt FY11 |  | 178d | 2010-01-20 A | 2010-09-30 A | 16111005 FS+10d | 100% |  |  | MECH ENG [15.36 h]; MECH TECH [537.72 h]; MECH DES [15.36 h]; OFFICE [215.09 h]; ELEC ENG [30.73 h]; PLANT ENG [506.99 h] | 65,399.95 | 65,399.95 | 0 | 67483.9842 | WHITLATCH C | 1 | 1 |  | C | REBECCA Y |  |  |  |  |  |  |  |  |  | 10-028 | 11-055 | 12-029F |  |  |  |  |  |  |  |  | 10-032 |  | 07-029 | NB | 11-001 |
| 16111015 |  | N&S Access Addition Bldng Cmmssng |  | 21d | 2010-09-01 A | 2010-09-30 A | 16111010, 16111012, 16111010N | 100% |  |  | PROCUREMENT<$50K 60 | 4,682.75 |  | 0 | 4682.75 | WHITLATCH C | 1 | 1 |  | H | REBECCA Y |  |  |  |  |  |  | 100 |  |  | 10-028 | 11-055 | 12-029F | 0 | 4682.75 | 468275 | APP |  |  |  |  | 10-032 |  |  |  |  |
| 16111025 |  | N&S Access Addition Beneficial Occupancy |  | 10d | 2010-10-01 A | 2010-10-14 A | 16111015 | 100% |  |  | PLANT ENG [80 h] | 5,445.6 | 5,445.6 | 0 | 5445.6 | WHITLATCH C | 1 | 1 |  | H | REBECCA Y |  |  |  |  |  |  |  |  |  | 10-028 | 11-055 | 12-029F |  |  |  |  |  |  |  |  | 10-032 |  |  |  |  |
| 16111030M |  | N&S Access Addition Constr Compltn | milestone | 0d | 2010-10-14 A | 2010-10-14 A | 16111025, 16111020a, 16111020 | 100% | 2010-11-30 | 2010-11-30 |  |  |  |  | 0 | WHITLATCH C | 1 | 1 |  | M | REBECCA Y |  |  |  |  |  |  |  |  | 6 | 10-028 | 11-055 | 12-029F |  |  |  |  |  |  |  |  | 10-032 |  |  |  |  |
| 16111035 |  | Re-Baseline Actuals Adjustment |  | 1d | 2013-08-30 A | 2013-08-30 A |  | 100% | 2013-09-03 | 2013-09-03 | PROCUREMENT>$50K 69 NO ESCALATION | -106,587.34 |  |  |  |  |  |  |  |  |  |  |  |  |  |  |  | 100 | ADJ |  |  |  |  |  |  |  |  |  |  |  |  |  |  |  |  |  |

Notes:
- 16111020: Explanation: Progressed the same as 16111010A-N Total % PMK / 5/4/10
- 16111020a: Explanation: Progressed the same as 16111010A-N Total % PMK / 5/4/10

| ID | WBS | Activity | Type | Duration | Start | Finish | Predecessors | Complete | Planned start | Planned finish | Total float | Free float | Calendar | Resources | Cost | Actual cost | Calculated Remaining Total Cost | MONTHLY EV COST | RESP - Responsibility | STRT%COMP for CM EVM | FNSH%COMP for CM EVM | EVMS Reporting Codes | CAM RESPONSIBLE | CR 10-020 | CR 11-016 | CR 12-015 | Milestone Level | Remaining Material Cost Based on % Compl | Claimed Material Cost Based on % Complet | Initial Claimed Material Calc | Claimed Material Divider | CR 07-031 | Advance Purchase Plan > 500K | CR 08-014 | CR 08-016 | 12 GEV MAJOR PROCUREMENT CATAGORY | CR 09-012 | CR 10-032 | LOE % Pre Calc | LOE % | LOE Divider | LOE Multiplier | CR 07-029 | CR 12-001 | ReBaseline Actuals Adjustment | Original Activity ID Rebaseline | BOE Labor | BOE Adder | CR 13-015 | Post Rebaseline | CR 14-001 | BOE NOTES | BOE Procurement | Specification | MARCH!!! |
| --- | --- | --- | --- | --- | --- | --- | --- | --- | --- | --- | --- | --- | --- | --- | --- | --- | --- | --- | --- | --- | --- | --- | --- | --- | --- | --- | --- | --- | --- | --- | --- | --- | --- | --- | --- | --- | --- | --- | --- | --- | --- | --- | --- | --- | --- | --- | --- | --- | --- | --- | --- | --- | --- | --- | --- |
|  | 2 | **1.6.1.1.2 NORTH & SOUTH ACCESS BUILDING UTILITIES** |  |  | 2010-02-02 | 2015-10-02 |  |  |  |  |  |  |  |  |  |  |  |  |  |  |  |  |  |  |  |  |  |  |  |  |  |  |  |  |  |  |  |  |  |  |  |  |  |  |  |  |  |  |  |  |  |  |  |  |  |
| 16112000 |  | Redesign N&S Access LCW Upgrades |  | 169d | 2010-02-02 A | 2010-09-30 A | 9-100M FS+79d | 100% |  |  |  |  |  | ELEC ENG [160 h]; PLANT ENG [160 h]; SUPPLIES & MATERIALS; MECH ENG [320 h] | 45,230.4 | 42,230.4 | 0 | 45230.4 | WHITLATCH C | 1 | 1 | H | REBECCA Y | 10-020 | 11-016 | 12-015 |  |  |  |  |  |  |  |  |  |  |  |  |  |  |  |  |  |  |  |  |  |  |  |  |  |  |  |  |  |
| 16112005 |  | N&S Access LCW Upgrades Award Contract |  | 44d | 2010-10-18 A | 2010-12-20 A | 16112000M | 100% |  |  |  |  |  | MECH ENG [80 h] | 5,436 | 5,436 | 0 | 5268 | WHITLATCH C | 1 | 1 | H | REBECCA Y | 10-020 | 11-016 | 12-015 |  |  |  |  |  |  |  |  |  |  |  |  |  |  |  |  |  |  |  |  |  |  |  |  |  |  |  |  |  |
| 16112000M |  | N&S Access LCW Upgrades Begin Constr | milestone | 0d | 2010-10-26 A | 2010-10-26 A | 16112000 FS+10d, 1241075M, 1241195M | 100% | 2010-11-01 | 2010-11-01 |  |  |  |  |  |  |  | 0 | WHITLATCH C | 1 | 1 | M | REBECCA Y |  | 11-016 | 12-015 | 6 |  |  |  |  |  |  |  |  |  |  |  |  |  |  |  |  |  |  |  |  |  |  |  |  |  |  |  |  |
| 16112010 |  | West Arc LCW Header installation |  | 17d | 2010-12-01 A | 2010-12-30 A | 16112005 FS-11d, 16111025 FS-70d | 100% |  |  |  |  |  | PROCUREMENT<$50K 60; PROCUREMENT>$50K 69 | 250,000 |  | 0 | 250000 | WHITLATCH C | 1 | 1 | C | REBECCA Y | 10-020 | 11-016 | 12-015 |  | 0 | 250000 | 25000000 | 100 | 07-031 | APP | 08-014 | 08-016 | 6112 | 09-012 | 10-032 |  |  |  |  |  |  |  |  |  |  |  |  |  |  |  |  |  |
| 16112020 |  | N&S Access LCW Upgrades Constrctn Mngmnt FY11 |  | 209.46d | 2010-12-01 A | 2011-10-05 A | 16112005 FS-11d | 100% |  |  |  |  |  | OFFICE [236.57 h]; ELEC ENG [394.29 h]; PLANT ENG [276 h]; MECH ENG [1104 h]; MECH TECH [867.43 h]; MECH DES [39.43 h] | 166,574.74 | 167,059.67 | 0 | 166512.3646 | WHITLATCH C | 1 | 1 | E | REBECCA Y | 10-020 | 11-016 | 12-015 |  |  |  |  |  |  |  |  |  |  |  | 10-032 | 1.42857142 | 98.57142857 | 100 | 100 | 07-029 | 12-001 |  |  |  |  |  |  |  |  |  |  |  |
| 16112020a |  | N&S Access LCW Upgrades Constrctn Mngmnt FY12 |  | 210d | 2010-12-01 A | 2011-10-05 A | 16112020 FS-5d | 100% |  |  |  |  |  | MECH DES [0.57 h]; MECH TECH [12.57 h]; ELEC ENG [5.71 h]; MECH ENG [16 h]; PLANT ENG [4 h]; OFFICE [3.43 h] | 2,413.94 | 2,413.94 | 0 | 2489.7718 | WHITLATCH C | 1 | 1 | E | REBECCA Y | 10-020 | 11-016 | 12-015 |  |  |  |  |  |  |  |  |  |  |  | 10-032 |  |  | 100 | 100 | 07-029 | 12-001 |  |  |  |  |  |  |  |  |  |  |  |
| 16112015 |  | N&S Access LCW Upgrades Bldng Cmmssng |  | 64d | 2011-07-11 A | 2011-10-07 A | 1961005 FS-85d, 16112010, 1961000n FS-85d | 100% |  |  |  |  |  | PROCUREMENT<$50K 60 | 45,353.46 |  | 0 | 45353.46 | WHITLATCH C | 1 | 1 | H | REBECCA Y | 10-020 | 11-016 | 12-015 |  | 0 | 45353.46 | 4535346 | 100 |  | APP |  |  |  |  | 10-032 |  |  |  |  |  |  |  |  |  |  |  |  |  |  |  |  |  |
| 16112025 |  | N&S Access LCW Upgrades Beneficial Occupancy |  | 88d | 2011-09-19 A | 2012-01-31 A | 16112015 FS-20d | 100% |  |  |  |  |  | MECH ENG [80 h] | 5,589.87 | 5,589.87 | 0 | 5609.6 | WHITLATCH C | 1 | 1 | H | REBECCA Y | 10-020 | 11-016 | 12-015 |  |  |  |  |  |  |  |  |  |  |  | 10-032 |  |  |  |  |  |  |  |  |  |  |  |  |  |  |  |  |  |
| 16112035 |  | Re-Baseline Actuals Adjustment |  | 1d | 2013-08-30 A | 2013-08-30 A |  | 100% | 2013-09-03 | 2013-09-03 |  |  |  | PROCUREMENT>$50K 69 NO ESCALATION | 45,874.97 |  |  | 45874.97 |  |  |  |  |  |  |  |  |  | 0 | 45874.97 | 4587497 | 100 |  |  |  |  |  |  |  |  |  |  |  |  |  | ADJ |  |  |  |  |  |  |  |  |  |  |
| 26112011 |  | Redundant Cooling Towers Award Contract |  | 60d | 2014-10-01 | 2015-01-06 | 9-155M |  |  |  | 249d | 0d | 8/5 M-F w/JLAB Holidays ReBaseline | MECH ENG [80 h] | 5,973.6 |  |  | 0 | YASKY R | 1 | 1 |  | REBECCA Y |  | 11-016 | 12-015 |  |  |  |  |  |  | APP |  |  | 6112 |  |  |  |  |  |  |  |  |  | 26112011 | EJ | NO | 13-015 | PR | 14-001 |  |  |  |  |
| 26112012 |  | Redundant Cooling Towers |  | 188d | 2015-01-07 | 2015-10-02 | 26112011 |  |  |  | 249d | 0d | 8/5 M-F w/JLAB Holidays ReBaseline | PROCUREMENT<$50K 60; PROCUREMENT>$50K 69 | 399,306.6 |  |  | 0 | YASKY R | 1 | 1 |  | REBECCA Y |  | 11-016 | 12-015 |  | 399306.6 | 0 | 0 | 100 |  | APP |  |  | 6112 |  |  |  |  |  |  |  |  |  | 26112012 |  | YES | 13-015 | PR | 14-001 | -10% Bid previously | EV |  |  |
| 26112013 |  | Redundant Cooling Towers Construction Management |  | 187d | 2015-01-07 | 2015-10-01 | 26112011 |  |  |  | 250d | 1d | 8/5 M-F w/JLAB Holidays ReBaseline | OFFICE [80 h]; MECH TECH [400 h]; MECH ENG [320 h] | 45,254.4 |  |  | 0 | YASKY R | 1 | 1 |  | REBECCA Y |  | 11-016 | 12-015 |  |  |  |  |  |  | APP |  |  | 6112 |  |  |  |  |  |  |  |  |  | 26112013 | EJ | NO | 13-015 | PR | 14-001 |  |  |  |  |
| 26112030M |  | N&S Access LCW Upgrades Constr Comp | milestone | 0d | 2015-10-02 | 2015-10-02 | 26112012, 26112013 |  |  |  | 249d | 0d | 8/5 M-F w/JLAB Holidays ReBaseline |  |  |  |  | 0 | YASKY R | 1 | 1 |  | REBECCA Y | 10-020 | 11-016 | 12-015 | 6 |  |  |  |  |  |  |  |  |  |  | 10-032 |  |  |  |  |  |  |  | 26112030M |  |  | 13-015 | PR |  |  |  |  |  |
|  | 3 | **1.6.1.1.3 BEAM SWITCHYARD SERVICE BUILDING ADDITION** |  |  | 2011-01-21 | 2013-08-30 |  |  |  |  |  |  |  |  |  |  |  |  |  |  |  |  |  |  |  |  |  |  |  |  |  |  |  |  |  |  |  |  |  |  |  |  |  |  |  |  |  |  |  |  |  |  |  |  |  |
| 16113000M |  | BSY Addition Begin Proc. Prep | milestone | 0d | 2011-01-21 A | 2011-01-21 A | 9-110M FS+75d, 1241115M | 100% | 2011-02-01 | 2011-02-01 |  |  |  |  |  |  |  | 0 | WHITLATCH C | 1 | 1 | M | REBECCA Y |  |  |  | 6 |  |  |  |  |  |  |  |  |  |  |  |  |  |  |  |  |  |  |  |  |  |  |  |  |  |  |  |  |
| 16113005 |  | BSY Addition Award Contract |  | 45d | 2011-01-21 A | 2011-03-25 A | 16113000M | 100% |  |  |  |  |  | PLANT ENG [80 h] | 5,445.6 | 5,445.6 | 0 | 5445.6 | WHITLATCH C | 1 | 1 | H | REBECCA Y |  |  |  |  |  |  |  |  |  |  |  |  |  |  |  |  |  |  |  |  |  |  |  |  |  |  |  |  |  |  |  |  |
| 16113010 |  | BSY Addition Constrctn Contract Progress |  | 173d | 2011-03-28 A | 2011-11-30 A | 16113005 | 100% |  |  |  |  |  | PROCUREMENT>$50K 69 NO ESCALATION FY12; PROCUREMENT<$50K 60 NO ESCALATION FY12 | 208,625.92 |  | 0 | 208625.92 | WHITLATCH C | 1 | 1 | C | REBECCA Y |  |  |  |  | 0 | 208625.92 | 20862592 | 100 |  |  | 08-014 | 08-016 |  | 09-012 |  |  |  |  |  |  |  |  |  |  |  |  |  |  |  |  |  |  |
| 16113020 |  | BSY Addition Consrtuction Mngmnt FY11 |  | 172.1d | 2011-03-28 A | 2011-11-30 A | 16113005 | 100% |  |  |  |  |  | OFFICE [349.14 h]; ELEC ENG [53.71 h]; MECH ENG [53.71 h]; MECH TECH [644.57 h]; MECH DES [26.86 h]; PLANT ENG [617.71 h] | 88,699.44 | 89,152.81 | 0 | 88045.9625 | WHITLATCH C | 1 | 1 | C | REBECCA Y |  |  | 12-015 |  |  |  |  |  |  |  |  |  |  |  |  |  |  |  |  | 07-029 | 12-001 |  |  |  |  |  |  |  |  |  |  |  |
| 16113020a |  | BSY Addition Consrtuction Mngmnt FY12 |  | 173d | 2011-03-28 A | 2011-11-30 A | 16113020 FS-100d | 100% |  |  |  |  |  | MECH DES [13.14 h]; PLANT ENG [302.29 h]; OFFICE [170.86 h]; ELEC ENG [26.29 h]; MECH ENG [26.29 h]; MECH TECH [315.43 h] | 43,412.89 | 43,412.89 | 0 | 44460.0428 | WHITLATCH C | 1 | 1 | C | REBECCA Y |  |  | 12-015 |  |  |  |  |  |  |  |  |  |  |  |  |  |  |  |  | 07-029 | 12-001 |  |  |  |  |  |  |  |  |  |  |  |
| 16113015 |  | BSY Addition Bldng Cmmssng |  | 11d | 2011-10-16 A | 2011-10-31 A | 16113010 | 100% | 2011-10-17 | 2011-10-31 |  |  |  | PROCUREMENT<$50K 60 | 4,832.13 |  | 0 | 4832.13 | WHITLATCH C | 1 | 1 | H | REBECCA Y |  |  |  |  | 0 | 4832.13 | 483213 | 100 |  |  |  |  |  |  |  |  |  |  |  |  |  |  |  |  |  |  |  |  |  |  |  |  |
| 16113025 |  | BSY Addition Beneficial Occupancy |  | 4d | 2011-12-01 A | 2011-12-06 A | 16113015, 16113012 | 100% |  |  |  |  |  | PLANT ENG [80 h] | 5,619.2 | 5,619.2 | 0 | 5619.2 | WHITLATCH C | 1 | 1 | H | REBECCA Y |  |  |  |  |  |  |  |  |  |  |  |  |  |  |  |  |  |  |  |  |  |  |  |  |  |  |  |  |  |  |  |  |
| 16113030M |  | BSY Addition Constr Compltn | milestone | 0d | 2011-12-06 A | 2011-12-06 A | 16113020a, 16113025 | 100% | 2012-02-29 | 2012-02-29 |  |  |  |  |  |  |  | 0 | WHITLATCH C | 1 | 1 | M | REBECCA Y |  |  | 12-015 | 6 |  |  |  |  |  |  |  |  |  |  |  |  |  |  |  |  |  |  |  |  |  |  |  |  |  |  |  |  |
| 16113012 |  | BSY Modify LCW Piping |  | 181d | 2012-04-02 A | 2013-07-15 A | 16113010, 9-120M | 100% | 2012-04-02 | 2012-12-17 |  |  |  | MECH ENG [40 h]; PROCUREMENT<$50K 60; MECH TECH [80 h] | 8,760.64 | 6,482.81 | 0 | 8700.02 | WHITLATCH C | 1 | 1 | H | REBECCA Y |  |  |  |  | 0 | 2340.02 | 234002 | 100 |  |  |  |  |  |  |  |  |  |  |  |  |  |  |  |  |  |  |  |  |  |  | 16113012 | XX |
| 16113035 |  | Re-Baseline Actuals Adjustment |  | 1d | 2013-08-30 A | 2013-08-30 A |  | 100% | 2013-09-03 | 2013-09-03 |  |  |  | PROCUREMENT>$50K 69 NO ESCALATION | -95,702.62 |  |  |  |  |  |  |  |  |  |  |  |  |  |  |  | 100 |  |  |  |  |  |  |  |  |  |  |  |  |  | ADJ |  |  |  |  |  |  |  |  |  |  |

| ID | WBS | Activity | Type | Duration | Start | Finish | Predecessors | Complete | Planned start | Planned finish | Total float | Free float | Calendar | Resources | Cost | Actual cost | Remaining Material Cost Based on % Compl | Claimed Material Cost Based on % Complet | Initial Claimed Material Calc | Claimed Material Divider | MONTHLY EV COST | ReBaseline Actuals Adjustment | Original Activity ID Rebaseline | RESP - Responsibility | STRT%COMP for CM EVM | FNSH%COMP for CM EVM | Milestone Level | CAM RESPONSIBLE | CR 10-020 | CR 12-015 | Post Rebaseline | BOE Labor | BOE Adder | CR 13-015 | CR 14-001 | BOE NOTES | Advance Purchase Plan > 500K | CR 08-014 | CR 08-016 | 12 GEV MAJOR PROCUREMENT CATAGORY | CR 09-012 | BOE Procurement | CR 07-029 | Calculated Remaining Total Cost | EVMS Reporting Codes | CR 12-043 | MARCH!!! | LOE % Pre Calc | LOE % | LOE Divider | LOE Multiplier | PRIOR MONTH EV COST | Obligated Prior to Rebaseline | CR 10-010 | CR 10-033 | CR 10-041 | Activities with Steps |
| --- | --- | --- | --- | --- | --- | --- | --- | --- | --- | --- | --- | --- | --- | --- | --- | --- | --- | --- | --- | --- | --- | --- | --- | --- | --- | --- | --- | --- | --- | --- | --- | --- | --- | --- | --- | --- | --- | --- | --- | --- | --- | --- | --- | --- | --- | --- | --- | --- | --- | --- | --- | --- | --- | --- | --- | --- | --- |
|  | 4 | **1.6.1.1.4 TUNNEL AIR CONDITIONING** |  |  | 2013-08-30 | 2015-08-04 |  |  |  |  |  |  |  |  |  |  |  |  |  |  |  |  |  |  |  |  |  |  |  |  |  |  |  |  |  |  |  |  |  |  |  |  |  |  |  |  |  |  |  |  |  |  |  |  |  |  |  |
| 16114035 |  | Re-Baseline Actuals Adjustment |  | 1d | 2013-08-30 A | 2013-08-30 A |  | 100% | 2013-09-03 | 2013-09-03 |  |  |  | PROCUREMENT>$50K 69 NO ESCALATION | 22,325.85 |  | 0 | 22325.85 | 2232585 | 100 | 22325.85 | ADJ |  |  |  |  |  |  |  |  |  |  |  |  |  |  |  |  |  |  |  |  |  |  |  |  |  |  |  |  |  |  |  |  |  |  |  |
| 26114000M |  | Tunnel A/C Begin Constr | milestone | 0d | 2014-10-01 | 2014-10-01 | 9-155M |  |  |  | 291d | 0d | 8/5 M-F w/JLAB Holidays ReBaseline |  |  |  |  |  |  |  | 0 |  | 26114000M | YASKY R | 1 | 1 | 6 | REBECCA Y | 10-020 | 12-015 | PR |  |  |  |  |  |  |  |  |  |  |  |  |  |  |  |  |  |  |  |  |  |  |  |  |  |  |
| 26114005 |  | Tunnel A/C Award Contract |  | 65d | 2014-10-01 | 2015-01-13 | 26114000M |  |  |  | 291d | 0d | 8/5 M-F w/JLAB Holidays ReBaseline | MECH ENG [80 h] | 5,973.6 |  |  |  |  |  | 0 |  | 26114005 | YASKY R | 1 | 1 |  | REBECCA Y | 10-020 | 12-015 | PR | EJ | NO | 13-015 | 14-001 |  |  |  |  |  |  |  |  |  |  |  |  |  |  |  |  |  |  |  |  |  |  |
| 26114010 |  | Tunnel A/C Constrctn Contract Progress |  | 131d | 2015-01-14 | 2015-07-21 | 26114005 |  |  |  | 291d | 0d | 8/5 M-F w/JLAB Holidays ReBaseline | PROCUREMENT>$50K 69; PROCUREMENT<$50K 60 | 1,411,829.06 |  | 1411829.06 | 0 | 0 | 100 | 0 |  | 26114010 | YASKY R | 1 | 1 |  | REBECCA Y | 10-020 | 12-015 | PR |  | YES | 13-015 | 14-001 | +10% MEANS Est Manual | APP | 08-014 | 08-016 | 6114 | 09-012 | CP |  |  |  |  |  |  |  |  |  |  |  |  |  |  |  |
| 26114020 |  | Tunnel A/C Constrctn Mngmnt |  | 140d | 2015-01-14 | 2015-08-03 | 26114005 |  |  |  | 292d | 1d | 8/5 M-F w/JLAB Holidays ReBaseline | OFFICE [120 h]; ELEC ENG [40 h]; MECH ENG [640 h]; MECH TECH [520 h]; MECH DES [40 h] | 81,100.4 |  |  |  |  |  | 0 |  | 26114020 | YASKY R | 1 | 1 |  | REBECCA Y | 10-020 | 12-015 | PR | EJ | NO | 13-015 | 14-001 |  |  |  |  |  |  |  | 07-029 |  |  |  |  |  |  |  |  |  |  |  |  |  |  |
| 26114015 |  | Tunnel A/C Bldng Cmmssng |  | 5d | 2015-07-22 | 2015-07-28 | 26114010 |  |  |  | 291d | 0d | 8/5 M-F w/JLAB Holidays ReBaseline | PROCUREMENT<$50K 60 | 15,423.53 |  | 15423.53 | 0 | 0 | 100 | 0 |  | 26114015 | YASKY R | 1 | 1 |  | REBECCA Y | 10-020 | 12-015 | PR |  | NO | 13-015 | 14-001 |  | APP |  |  |  |  | PE |  |  |  |  |  |  |  |  |  |  |  |  |  |  |  |
| 26114025 |  | Tunnel A/C Beneficial Occupancy |  | 5d | 2015-07-29 | 2015-08-04 | 26114015 |  |  |  | 291d | 0d | 8/5 M-F w/JLAB Holidays ReBaseline | MECH ENG [80 h] | 5,973.6 |  |  |  |  |  | 0 |  | 26114025 | YASKY R | 1 | 1 |  | REBECCA Y | 10-020 | 12-015 | PR | EJ | NO | 13-015 | 14-001 |  |  |  |  |  |  |  |  |  |  |  |  |  |  |  |  |  |  |  |  |  |  |
| 26114030M |  | Tunnel A/C Constr Comp | milestone | 0d | 2015-08-04 | 2015-08-04 | 26114025, 26114020 |  |  |  | 291d | 42d | 8/5 M-F w/JLAB Holidays ReBaseline |  |  |  |  |  |  |  | 0 |  | 26114030M | YASKY R | 1 | 1 | 6 | REBECCA Y | 10-020 | 12-015 | PR |  |  | 13-015 |  |  |  |  |  |  |  |  |  |  |  |  |  |  |  |  |  |  |  |  |  |  |  |
|  | 5 | **1.6.1.1.5. N&S LINAC SERVICE BUILDING AIR CONDITIONING** |  |  | 2012-09-10 | 2013-10-31 |  |  |  |  |  |  |  |  |  |  |  |  |  |  |  |  |  |  |  |  |  |  |  |  |  |  |  |  |  |  |  |  |  |  |  |  |  |  |  |  |  |  |  |  |  |  |  |  |  |  |  |
| 16115005 |  | Design N&S Linac A/C |  | 64d | 2012-09-10 A | 2013-01-17 A | 9-130M | 100% | 2012-09-10 | 2012-12-10 |  |  |  | MECH ENG [120 h]; ELEC ENG [40 h]; PLANT ENG [40 h]; MECH DES [80 h] | 18,337.64 | 18,371.9 |  |  |  |  | 18471.6 |  |  | WHITLATCH C | 1 | 1 |  | REBECCA Y | 10-020 | 12-015 |  |  |  |  |  |  |  |  |  |  |  |  |  | 0 | H | 12-043 | XX |  |  |  |  |  |  |  |  |  |  |
| 16115010 |  | Design and Safety Review of N&S Linac A/C |  | 7d | 2013-01-18 A | 2013-02-01 A | 16115005 | 100% | 2013-02-14 | 2013-02-25 |  |  |  | MECH ENG [40 h] | 2,894.4 | 2,894.4 |  |  |  |  | 2894.4 |  |  | WHITLATCH C | 1 | 1 |  | REBECCA Y | 10-020 | 12-015 |  |  |  |  |  |  |  |  |  |  |  |  |  | 0 | H | 12-043 | XX |  |  |  |  |  |  |  |  |  |  |
| 16115015 |  | Finalize Design N&S Linac A/C |  | 8d | 2013-02-04 A | 2013-02-25 A | 16115010 | 100% | 2013-03-01 | 2013-03-12 |  |  |  | MECH ENG [40 h]; ELEC ENG [40 h]; MECH DES [40 h]; PLANT ENG [40 h] | 10,694.4 | 10,694.4 |  |  |  |  | 10694.4 |  |  | WHITLATCH C | 1 | 1 |  | REBECCA Y | 10-020 | 12-015 |  |  |  |  |  |  |  |  |  |  |  |  |  | 0 | H | 12-043 | XX |  |  |  |  |  |  |  |  |  |  |
| 16115020 |  | N&S Linac A/C Award Const Contract |  | 47d | 2013-02-11 A | 2013-04-15 A | 16115015 | 100% | 2013-03-01 | 2013-05-06 |  |  |  | MECH ENG [80 h] | 5,788.8 | 5,788.8 |  |  |  |  | 5788.8 |  |  | WHITLATCH C | 1 | 1 |  | REBECCA Y | 10-020 | 12-015 |  |  |  |  |  |  |  |  |  |  |  |  |  | 0 | H | 12-043 |  |  |  |  |  |  |  |  |  |  |  |
| 16115030 |  | N&S Linac A/C Construction Management |  | 140d | 2013-03-04 A | 2013-08-30 A | 16115020 FS-125d | 100% | 2013-05-14 | 2013-12-02 |  |  |  | MECH ENG [365.71 h]; ELEC ENG [73.14 h]; MECH TECH [329.14 h]; OFFICE [109.71 h] | 50,605.9 | 50,115.06 |  |  |  |  | 50115.046725 |  |  | WHITLATCH C | 1 | 1 |  | REBECCA Y | 10-020 | 12-015 |  |  |  |  |  |  |  |  |  |  |  |  |  | 13314.22344 | E | 12-043 |  | 8.57142857 | 91.42857142 | 100 | 100 |  |  |  |  |  |  |
| 16115025 |  | N&S Linac A/C Construction Contract Progress |  | 107d | 2013-04-15 A | 2013-08-30 A | 16115020 | 100% | 2013-05-22 | 2013-10-22 |  |  |  | PROCUREMENT<$50K 60; PROCUREMENT>$50K 69 | 250,037.31 |  | 0 | 250037.31 | 25003731 | 100 | 250037.31 |  |  | WHITLATCH C | 1 | 1 |  | REBECCA Y | 10-020 | 12-015 |  |  |  |  |  |  |  |  |  |  |  |  |  | 72233 | D | 12-043 |  |  |  |  |  |  |  |  |  |  |  |
| 16115050 |  | Re-Baseline Actuals Adjustment |  | 1d | 2013-08-30 A | 2013-08-30 A |  | 100% | 2013-09-03 | 2013-09-03 |  |  |  | PROCUREMENT>$50K 69 NO ESCALATION | 8,479.85 |  | 0 | 8479.85 | 847985 | 100 | 8479.85 | ADJ |  |  |  |  |  |  |  |  |  |  |  |  |  |  |  |  |  |  |  |  |  |  |  |  |  |  |  |  |  |  |  |  |  |  |  |
| 26115025 |  | N&S Linac A/C Construction Contract Progress |  | 38d | 2013-09-03 A | 2013-09-16 A | 9-130M FS+228d | 100% | 2013-10-01 | 2013-11-21 |  |  | 8/5 M-F w/JLAB Holidays ReBaseline | PROCUREMENT<$50K 60 NO ESCALATION FY14; PROCUREMENT>$50K 69 NO ESCALATION FY14 | 52,634.11 |  | 0 | 52634.11 | 5263411 | 100 | 0 |  | 26115025 | YASKY R | 1 | 1 |  | REBECCA Y | 10-020 | 12-015 | PR |  | YES | 13-015 |  | +10% MEANS Est Manual |  |  |  |  |  | CP |  |  | C | 12-043 |  |  |  |  |  | 52634.11 | OB |  |  |  |  |
| 26115030 |  | N&S Linac A/C Construction Management FY13 |  | 20d | 2013-09-03 A | 2013-09-30 A | 26115025 FS-38d | 100% | 2013-10-01 | 2013-10-28 |  |  | 8/5 M-F w/JLAB Holidays ReBaseline | MECH ENG [57.15 h]; ELEC ENG [11.43 h]; MECH TECH [51.44 h]; OFFICE [17.14 h] | 8,081.24 | 7,919.4 |  |  |  |  | 0 |  | 26115030 | YASKY R | 1 | 1 |  | REBECCA Y | 10-020 | 12-015 | PR | EJ | NO | 13-015 |  |  |  |  |  |  |  |  |  |  | E | 12-043 |  | 58.33333333 | 41.66666666 | 100 | 100 | 7831.4931 |  |  |  |  |  |
| 26115035 |  | N&S Linac A/C Building Commissioning |  | 5d | 2013-09-18 A | 2013-10-30 A | 26115025 | 100% | 2013-11-22 | 2013-12-02 |  |  | 8/5 M-F w/JLAB Holidays ReBaseline | MECH ENG [40 h] | 2,986.8 | 2,971.68 |  |  |  |  | 1493.4 |  | 26115035 | YASKY R | 1 | 1 |  | REBECCA Y | 10-020 | 12-015 | PR | EJ | NO | 13-015 | 14-001 |  |  |  |  |  |  | PE |  |  | H | 12-043 |  |  |  |  |  | 1493.4 |  |  |  |  |  |
| 26115040 |  | N&S Linac A/C Beneficial Occupancy |  | 5d | 2013-09-18 A | 2013-09-27 A | 26115035 | 100% | 2013-10-08 | 2013-10-14 |  |  | 8/5 M-F w/JLAB Holidays ReBaseline | MECH ENG [40 h] | 2,986.8 | 2,894.4 |  |  |  |  | 0 |  | 26115040 | YASKY R | 1 | 1 |  | REBECCA Y | 10-020 | 12-015 | PR | EJ | NO | 13-015 | 14-001 |  |  |  |  |  |  |  |  |  | H | 12-043 |  |  |  |  |  | 2986.8 |  |  |  |  |  |
| 26115030a |  | N&S Linac A/C Construction Management FY14 |  | 28d | 2013-10-01 A | 2013-10-30 A | 26115030 | 100% | 2013-11-01 | 2013-12-12 |  |  | 8/5 M-F w/JLAB Holidays ReBaseline | MECH ENG [80.01 h]; ELEC ENG [16 h]; MECH TECH [72.01 h]; OFFICE [24 h] | 11,313.5 | 11,313.5 |  |  |  |  | 11313.498367 |  | 26115030 | YASKY R | 1 | 1 |  | REBECCA Y | 10-020 | 12-015 | PR | EJ | NO | 13-015 | 14-001 |  |  |  |  |  |  |  |  |  | E | 12-043 |  | 17.85714285 | 82.14285714 | 100 | 100 |  |  |  |  |  |  |
| 26115045M |  | N&S Linac A/C Construction Complete | milestone | 0d | 2013-10-31 A | 2013-10-31 A | 26115030, 26115030a, 26115040 | 100% | 2013-12-05 | 2013-12-05 |  |  | 8/5 M-F w/JLAB Holidays ReBaseline |  |  |  |  |  |  |  | 0 |  | 26115045M | YASKY R | 1 | 1 |  | REBECCA Y | 10-020 | 12-015 | PR |  |  | 13-015 |  |  |  |  |  |  |  |  |  |  | M | 12-043 |  |  |  |  |  |  |  |  |  |  |  |
|  | 2 | **1.6.1.2 SITEWORK** |  |  | 2009-11-09 | 2013-08-30 |  |  |  |  |  |  |  |  |  |  |  |  |  |  |  |  |  |  |  |  |  |  |  |  |  |  |  |  |  |  |  |  |  |  |  |  |  |  |  |  |  |  |  |  |  |  |  |  |  |  |  |
|  | 1 | **1.6.1.2.1** |  |  |  |  |  |  |  |  |  |  |  |  |  |  |  |  |  |  |  |  |  |  |  |  |  |  |  |  |  |  |  |  |  |  |  |  |  |  |  |  |  |  |  |  |  |  |  |  |  |  |  |  |  |  |  |
|  | 2 | **1.6.1.2.2 ELECTRICAL DISTRIBUTION - N&S LINAC** |  |  | 2009-11-09 | 2013-08-30 |  |  |  |  |  |  |  |  |  |  |  |  |  |  |  |  |  |  |  |  |  |  |  |  |  |  |  |  |  |  |  |  |  |  |  |  |  |  |  |  |  |  |  |  |  |  |  |  |  |  |  |
| 16122005 |  | N&S Linac Award Contract (ED) |  | 45d | 2009-11-09 A | 2010-01-21 A | 16122000M FS-1000d | 100% |  |  |  |  |  | ELEC ENG [80 h] | 5,301.6 | 5,301.6 |  |  |  |  | 5470.4 |  |  | WHITLATCH C | 1 | 1 |  | REBECCA Y |  |  |  |  |  |  |  |  |  |  |  |  |  |  |  | 0 | H |  |  |  |  |  |  |  |  |  |  |  |  |
| 16122000M |  | Electrical Distrbtn N&S Linac Begin Constr | milestone | 0d | 2009-12-01 A | 2009-12-01 A | 1241195M | 100% | 2010-10-01 | 2010-10-01 |  |  |  |  |  |  |  |  |  |  | 0 |  |  | WHITLATCH C | 1 | 1 | 6 | REBECCA Y |  |  |  |  |  |  |  |  |  |  |  |  |  |  |  |  | M |  |  |  |  |  |  |  |  |  |  |  |  |
| 16122010 |  | N&S Linac Constrctn Contract Progress (ED) May Progress Payment |  | 113d | 2010-01-21 A | 2010-06-30 A | 9-100M FS+71d, 16122005 FS-250d | 100% |  |  |  |  |  | PROCUREMENT<$50K 60 | 5,399 |  | 0 | 5399 | 539900 | 100 | 5399 |  |  | WHITLATCH C | 1 | 1 |  | REBECCA Y |  |  |  |  |  |  |  |  | APP | 08-014 |  |  |  |  |  | 0 | P |  |  |  |  |  |  |  |  | 10-010 | 10-033 | 10-041 |  |
| 16122010A |  | N&S Linac Constrctn Contract Progress (ED) June Progress Payment |  | 132d | 2010-01-21 A | 2010-07-28 A | 16122010 FS-91d | 100% |  |  |  |  |  | PROCUREMENT<$50K 60; PROCUREMENT>$50K 69 | 51,585 |  | 0 | 51585 | 5158500 | 100 | 51585 |  |  | WHITLATCH C | 1 | 1 |  | REBECCA Y |  |  |  |  |  |  |  |  | APP |  |  |  |  |  |  | 0 | C |  |  |  |  |  |  |  |  |  |  | 10-041 |  |
| 16122010B |  | N&S Linac Constrctn Contract Progress (ED) July Progress Payment |  | 156d | 2010-01-21 A | 2010-08-31 A | 16122010A FS-113d | 100% |  |  |  |  |  | PROCUREMENT>$50K 69 | 123,003 |  | 0 | 123003 | 12300300 | 100 | 123003 |  |  | WHITLATCH C | 1 | 1 |  | REBECCA Y |  |  |  |  |  |  |  |  | APP |  |  |  |  |  |  | 0 | C |  |  |  |  |  |  |  |  |  |  | 10-041 |  |
| 16122010C |  | N&S Linac Constrctn Contract Progress (ED) August Progress Payment |  | 177d | 2010-01-21 A | 2010-09-30 A | 16122010B FS-134d | 100% |  |  |  |  |  | PROCUREMENT>$50K 69 | 322,250 |  | 0 | 322250 | 32225000 | 100 | 322250 |  |  | WHITLATCH C | 1 | 1 |  | REBECCA Y |  |  |  |  |  |  |  |  | APP |  |  |  |  |  |  | 0 | C |  |  |  |  |  |  |  |  |  |  | 10-041 |  |
| 16122010D |  | N&S Linac Constrctn Contract Progress (ED)September Progress Payment |  | 183d | 2010-01-21 A | 2010-10-08 A | 16122010C FS-156d | 100% |  |  |  |  |  | PROCUREMENT>$50K 69 | 14,763 |  | 0 | 14763 | 1476300 | 100 | 14763 |  |  | WHITLATCH C | 1 | 1 |  | REBECCA Y |  |  |  |  |  |  |  |  | APP |  |  |  |  |  |  | 0 | C |  |  |  |  |  |  |  |  |  |  | 10-041 |  |
| 16122012 |  | N&S Linac Constrctn Contract Modifications (ED) |  | 194d | 2010-01-21 A | 2010-10-25 A | 16122010D FS-177d, 16122010 FS-113d | 100% |  |  |  |  |  | PROCUREMENT>$50K 69 NO ESCALATION | 26,000 |  | 0 | 26000 | 2600000 | 100 | 26000 |  |  | WHITLATCH C | 1 | 1 |  | REBECCA Y |  |  |  |  |  |  |  |  |  | 08-014 |  |  |  |  |  | 0 | C |  |  |  |  |  |  |  |  | 10-010 | 10-033 | 10-041 |  |
| 16122020 |  | N&S Linac Constrctn Mngmnt (ED) |  | 194d | 2010-01-21 A | 2010-10-25 A | 9-100M FS+71d, 16122005 FS-250d | 100% |  |  |  |  |  | ELEC ENG [440 h]; MECH TECH [200 h]; MECH DES [40 h]; OFFICE [120 h] | 42,652.35 | 42,652.35 |  |  |  |  | 42533.6 |  |  | WHITLATCH C | 1 | 1 |  | REBECCA Y |  | 12-015 |  |  |  |  |  |  |  |  |  |  |  |  | 07-029 | 0 | S |  |  |  |  |  |  |  |  |  | 10-033 |  | NB |
| 16122015 |  | N&S Linac Bldng Cmmssng (ED) |  | 38d | 2010-09-01 A | 2010-10-25 A | 16122012 FS-6d, 16122010, 16122010D FS-6d | 100% |  |  |  |  |  | PROCUREMENT<$50K 60 | 11,701.2 |  | 0 | 11701.2 | 1170120 | 100 | 11701.2 |  |  | WHITLATCH C | 1 | 1 |  | REBECCA Y |  |  |  |  |  |  |  |  |  |  |  |  |  |  |  | 0 | H |  |  |  |  |  |  |  |  |  | 10-033 | 10-041 |  |
| 16122025 |  | N&S Linac Beneficial Occupancy (ED) |  | 6d | 2010-10-18 A | 2010-10-25 A | 16122015 | 100% |  |  |  |  |  | ELEC ENG [40 h] | 2,735.2 | 2,735.2 |  |  |  |  | 2735.2 |  |  | WHITLATCH C | 1 | 1 |  | REBECCA Y |  |  |  |  |  |  |  |  |  |  |  |  |  |  |  | 0 | H |  |  |  |  |  |  |  |  |  | 10-033 | 10-041 |  |
| 16122030M |  | Electrical Distrbtn N&S Linac Constr Comp | milestone | 0d | 2010-10-25 A | 2010-10-25 A | 16122025, 16122020 | 100% | 2010-11-01 | 2010-11-01 |  |  |  |  |  |  |  |  |  |  | 0 |  |  | WHITLATCH C | 1 | 1 | 6 | REBECCA Y |  | 12-015 |  |  |  |  |  |  |  |  |  |  |  |  |  |  | M |  |  |  |  |  |  |  |  |  | 10-033 | 10-041 |  |
| 16122035 |  | Re-Baseline Actuals Adjustment |  | 1d | 2013-08-30 A | 2013-08-30 A |  | 100% | 2013-09-03 | 2013-09-03 |  |  |  | PROCUREMENT>$50K 69 NO ESCALATION | -17,055.89 |  |  |  |  | 100 |  | ADJ |  |  |  |  |  |  |  |  |  |  |  |  |  |  |  |  |  |  |  |  |  |  |  |  |  |  |  |  |  |  |  |  |  |  |  |

Notes:
- 16122020: Explanation: Follows same progress as 16122010

| ID | WBS | Activity | Type | Duration | Start | Finish | Predecessors | Complete | Planned start | Planned finish | Resources | Cost | Actual cost | Calculated Remaining Total Cost | MONTHLY EV COST | RESP - Responsibility | STRT%COMP for CM EVM | FNSH%COMP for CM EVM | EVMS Reporting Codes | CAM RESPONSIBLE | CR 08-058 | Remaining Material Cost Based on % Compl | Claimed Material Cost Based on % Complet | Initial Claimed Material Calc | Claimed Material Divider | CR 09-009 | Advance Purchase Plan > 500K | CR 08-014 | CR 08-016 | 12 GEV MAJOR PROCUREMENT CATAGORY | LOE Divider | LOE Multiplier | CR 07-029 | CR 10-001 | CR 09-012 | CR 09-024 | CR 09-009A | Notebook Entry for S | Activities with Steps | CR 09-036 | CR 12-018 | CR 12-029 | CR 12-032 | CR 12-015 | ReBaseline Actuals Adjustment | CR 10-021 | CR 10-058 | Milestone Level | CR 10-071 | LOE % Pre Calc | LOE % | CR 11-001 |
| --- | --- | --- | --- | --- | --- | --- | --- | --- | --- | --- | --- | --- | --- | --- | --- | --- | --- | --- | --- | --- | --- | --- | --- | --- | --- | --- | --- | --- | --- | --- | --- | --- | --- | --- | --- | --- | --- | --- | --- | --- | --- | --- | --- | --- | --- | --- | --- | --- | --- | --- | --- | --- |
|  | 3 | **1.6.1.2.3** |  |  |  |  |  |  |  |  |  |  |  |  |  |  |  |  |  |  |  |  |  |  |  |  |  |  |  |  |  |  |  |  |  |  |  |  |  |  |  |  |  |  |  |  |  |  |  |  |  |  |
|  | 4 | **1.6.1.2.4** |  |  |  |  |  |  |  |  |  |  |  |  |  |  |  |  |  |  |  |  |  |  |  |  |  |  |  |  |  |  |  |  |  |  |  |  |  |  |  |  |  |  |  |  |  |  |  |  |  |  |
|  | 5 | **1.6.1.2.5** |  |  |  |  |  |  |  |  |  |  |  |  |  |  |  |  |  |  |  |  |  |  |  |  |  |  |  |  |  |  |  |  |  |  |  |  |  |  |  |  |  |  |  |  |  |  |  |  |  |  |
|  | 6 | **1.6.1.2.6** |  |  |  |  |  |  |  |  |  |  |  |  |  |  |  |  |  |  |  |  |  |  |  |  |  |  |  |  |  |  |  |  |  |  |  |  |  |  |  |  |  |  |  |  |  |  |  |  |  |  |
|  | 7 | **1.6.1.2.7** |  |  |  |  |  |  |  |  |  |  |  |  |  |  |  |  |  |  |  |  |  |  |  |  |  |  |  |  |  |  |  |  |  |  |  |  |  |  |  |  |  |  |  |  |  |  |  |  |  |  |
|  | 2 | **1.6.2 CHL** |  |  | 2008-12-15 | 2013-08-30 |  |  |  |  |  |  |  |  |  |  |  |  |  |  |  |  |  |  |  |  |  |  |  |  |  |  |  |  |  |  |  |  |  |  |  |  |  |  |  |  |  |  |  |  |  |  |
|  | 1 | **1.6.2.1 CHL BUILDING ADDITION** |  |  | 2008-12-15 | 2013-08-30 |  |  |  |  |  |  |  |  |  |  |  |  |  |  |  |  |  |  |  |  |  |  |  |  |  |  |  |  |  |  |  |  |  |  |  |  |  |  |  |  |  |  |  |  |  |  |
| 1621005 |  | Prcrmnt Prep for CHL Addition to Award Contract |  | 5d | 2008-12-15 A | 2008-12-19 A | 1621005X | 100% |  |  | PLANT ENG [12.57 h] | 803.6 | 803.6 | 0 | 803.6001 | CHANDRA S | 1 | 1 | H | REBECCA Y | 08-058 |  |  |  |  |  |  |  |  |  |  |  |  |  |  |  |  |  |  |  |  |  |  |  |  |  |  |  |  |  |  |  |
| 1621009 |  | CHL Addition Constrctn Contract Award (BONDS) |  | 5d | 2009-01-05 A | 2009-01-09 A | 1621005 FS-12d, 3C-04M FS-12d | 100% |  |  | PROCUREMENT>$50K 69; PROCUREMENT<$50K 60 | 50,000 |  | 0 | 50000 | CHANDRA S | 1 | 1 | P | REBECCA Y |  | 0 | 50000 | 5000000 | 100 | 09-009 | APP | 08-014 | 08-016 | 621 |  |  |  |  |  |  |  |  |  |  |  |  |  |  |  |  |  |  |  |  |  |  |
| 1621015 |  | CHL Addition Constrctn Mngmnt FY09 |  | 181d | 2009-01-13 A | 2009-09-30 A | 1621005 FS-12d | 100% | 2009-01-13 | 2009-09-29 | OFFICE [176 h]; MECH TECH [1114.67 h]; MECH ENG [29.33 h]; MECH DES [29.33 h]; ELEC ENG [29.33 h]; PLANT ENG [674.67 h] | 97,833.78 | 97,885.55 | 0 | 97833.775 | CHANDRA S | 1 | 1 | E | REBECCA Y |  |  |  |  |  | 09-009 |  |  |  |  | 100 | 100 | 07-029 | 10-001B |  |  |  |  |  |  |  |  |  |  |  |  |  |  |  |  |  |  |
| 1621010 |  | CHL Addition Constrctn Contract Progress |  | 307d | 2009-02-02 A | 2010-04-26 A | 1621009 | 100% |  |  | PROCUREMENT>$50K 69 NO ESCALATION; PROCUREMENT<$50K 60 NO ESCALATION | 1,502,200 |  | 0 | 1502200 | CHANDRA S | 1 | 1 | C | REBECCA Y |  | 0 | 1502200 | 150220000 | 100 | 09-009 | APP | 08-014 | 08-016 | 621 |  |  |  | 10-001A | 09-012 | 09-024 | 09-009A |  |  |  |  |  |  |  |  |  |  |  |  |  |  |  |
| 1621020 |  | CHL Addition A/E Supprt |  | 406d | 2009-02-02 A | 2010-09-15 A | 1621005 FS-12d | 100% |  |  | PROCUREMENT>$50K 69 NO ESCALATION; PROCUREMENT<$50K 60 NO ESCALATION | 61,540.07 |  | 0 | 61540.07 | CHANDRA S | 1 | 1 | S | REBECCA Y |  | 0 | 61540.07 | 6154007 | 100 | 09-009 | APP |  | 08-016 | 621 |  |  |  | 10-001A | 09-012 |  |  | Notebook Entry for S | NB |  |  |  |  |  |  |  |  |  |  |  |  |  |
| 1621011LOE |  | PPI Adjustment FY09 |  | 86d | 2009-06-01 A | 2009-09-30 A | 9-090M FS+162d | 100% |  |  | SUPPLIES & MATERIALS | 12,728 |  | 0 | 12728 | CHANDRA S | 1 | 1 | E | REBECCA Y |  |  |  |  |  |  | APP |  |  | 621 | 100 | 100 |  | 10-001B |  |  |  |  |  | 09-036 | 12-018F | 12-029F | 12-032F |  |  |  |  |  |  |  |  |  |
| 1621011LOEb |  | PPI Adjustment FY10 |  | 47d | 2009-10-01 A | 2009-12-08 A | 1621011LOE | 100% |  |  | SUPPLIES & MATERIALS | 7,177.9 |  | 0 | 7177.8964 | CHANDRA S | 1 | 1 | E | REBECCA Y |  |  |  |  |  |  | APP |  |  | 621 | 100 | 100 |  | 10-001B |  |  |  |  |  |  | 12-018F | 12-029F | 12-032F |  |  |  |  |  |  |  |  |  |
| 1621015b |  | CHL Addition Constrctn Mngmnt FY10 |  | 72d | 2009-10-01 A | 2010-01-21 A | 1621015 | 100% |  |  | ELEC ENG [10.67 h]; PLANT ENG [245.33 h]; OFFICE [64 h]; MECH ENG [10.67 h]; MECH DES [10.67 h]; MECH TECH [405.33 h] | 36,711.16 | 36,711.16 | 0 | 36711.1655 | CHANDRA S | 1 | 1 | E | REBECCA Y |  |  |  |  |  |  |  |  |  |  | 100 | 100 |  | 10-001B |  |  |  |  |  |  |  |  |  |  |  |  |  |  |  |  |  |  |
| 1621025 |  | CHl Addition Cmmssng |  | 11d | 2010-04-26 A | 2010-05-10 A | 1621010, 1621011LOEb | 100% |  |  | PROCUREMENT<$50K 60 NO ESCALATION | 19,784.31 |  | 0 | 19784.31 | CHANDRA S | 1 | 1 | H | REBECCA Y |  | 0 | 19784.31 | 1978431 | 100 | 09-009 | APP |  |  | 621 |  |  |  | 10-001A |  |  |  |  |  |  | 12-018F | 12-029F | 12-032F |  |  |  |  |  |  |  |  |  |
| 1621030 |  | CHL Addition Beneficial Occupancy |  | 15d | 2010-04-26 A | 2010-05-14 A | 1621025 FS-15d | 100% |  |  | PLANT ENG [40 h] | 2,638.8 | 2,638.8 | 0 | 2638.8 | CHANDRA S | 1 | 1 | H | REBECCA Y |  |  |  |  |  | 09-009 |  |  |  |  |  |  |  |  |  |  |  |  |  |  |  |  |  | 12-015 |  |  |  |  |  |  |  |  |
| 1621035 |  | Re-Baseline Actuals Adjustment |  | 1d | 2013-08-30 A | 2013-08-30 A |  | 100% | 2013-09-03 | 2013-09-03 | PROCUREMENT>$50K 69 NO ESCALATION | 1,304.44 |  |  | 1304.44 |  |  |  |  |  |  | 0 | 1304.44 | 130444 | 100 |  |  |  |  |  |  |  |  |  |  |  |  |  |  |  |  |  |  |  | ADJ |  |  |  |  |  |  |  |
|  | 2 | **1.6.2.2 SITEWORK** |  |  | 2010-02-01 | 2013-08-30 |  |  |  |  |  |  |  |  |  |  |  |  |  |  |  |  |  |  |  |  |  |  |  |  |  |  |  |  |  |  |  |  |  |  |  |  |  |  |  |  |  |  |  |  |  |  |
| 1622000 |  | Re-Baseline Actuals Adjustment |  | 1d | 2013-08-30 A | 2013-08-30 A |  | 100% | 2013-09-03 | 2013-09-03 | PROCUREMENT>$50K 69 NO ESCALATION | -145,495.64 |  |  |  |  |  |  |  |  |  |  |  |  | 100 |  |  |  |  |  |  |  |  |  |  |  |  |  |  |  |  |  |  |  | ADJ |  |  |  |  |  |  |  |
|  | 1 | **1.6.2.2.1** |  |  |  |  |  |  |  |  |  |  |  |  |  |  |  |  |  |  |  |  |  |  |  |  |  |  |  |  |  |  |  |  |  |  |  |  |  |  |  |  |  |  |  |  |  |  |  |  |  |  |
|  | 2 | **1.6.2.2.2 ELECTRICAL DISTRIBUTION** |  |  | 2010-02-02 | 2011-10-12 |  |  |  |  |  |  |  |  |  |  |  |  |  |  |  |  |  |  |  |  |  |  |  |  |  |  |  |  |  |  |  |  |  |  |  |  |  |  |  |  |  |  |  |  |  |  |
| 16222000 |  | Redesign CHL Utilities Upgrades |  | 34d | 2010-02-02 A | 2010-03-22 A | 9-100M FS+78d | 100% |  |  | MECH ENG [240 h]; ELEC ENG [120 h]; PLANT ENG [40 h]; PROCUREMENT>$50K 69; PROCUREMENT<$50K 60 | 96,395.2 | 26,395.2 | 0 | 96395.2 | CHANDRA S | 1 | 1 | H | REBECCA Y |  | 0 | 70000 | 7000000 | 100 |  |  |  |  |  |  |  |  |  |  |  |  |  |  |  |  |  |  |  |  | 10-021 |  |  |  |  |  |  |
| 16222007 |  | Elect Distrbtn Original Labor |  | 73d | 2010-02-02 A | 2010-05-14 A | 16222000M | 100% |  |  | ELEC ENG [80 h] | 5,301.6 | 5,301.6 | 0 | 5301.6 | CHANDRA S | 1 | 1 | H | REBECCA Y |  |  |  |  |  |  | APP |  |  | 6222A |  |  |  |  |  |  |  |  |  |  |  |  |  |  |  | 10-021 | 10-058 |  |  |  |  |  |
| 16222000M |  | Electrical Distrbtn Post Solicitation | milestone | 0d | 2010-03-25 A | 2010-03-25 A | 9-100M, 16222000 FS-130d | 100% | 2010-04-01 | 2010-04-01 |  |  |  |  | 0 | CHANDRA S | 1 | 1 | M | REBECCA Y |  |  |  |  |  |  |  |  |  |  |  |  |  |  |  |  |  |  |  |  |  |  |  |  |  | 10-021 | 10-058 | 6 |  |  |  |  |
| 16222005 |  | Elect Distrbtn Award Contract |  | 38d | 2010-03-25 A | 2010-05-17 A | 16222000, 16222000M | 100% |  |  | MECH ENG [40 h] | 2,634 | 2,634 | 0 | 2634 | CHANDRA S | 1 | 1 | H | REBECCA Y |  |  |  |  |  |  |  |  |  |  |  |  |  |  |  |  |  |  |  |  |  |  |  |  |  | 10-021 |  |  |  |  |  |  |
| 16222032 |  | Elect Distrbtn 40 MVA Switchgear Modification Labor Original |  | 20d | 2010-06-01 A | 2010-06-28 A | 9-100M FS+78d | 100% |  |  | ELEC ENG [138.35 h]; OFFICE [39.53 h]; MECH TECH [118.59 h] | 15,178.2 | 15,178.2 | 0 | 15178.2004 | CHANDRA S | 1 | 1 | H | REBECCA Y |  |  |  |  |  |  |  |  |  |  |  |  |  |  |  |  |  |  |  |  |  |  |  |  |  | 10-021 | 10-058 |  |  |  |  |  |
| 16222009 |  | CHL Utility Upgrades Modifications |  | 226d | 2010-07-01 A | 2011-05-31 A | 16222007, 16222005 | 100% |  |  | PROCUREMENT>$50K 69 NO ESCALATION; PROCUREMENT<$50K 60 NO ESCALATION | 112,000 |  | 0 | 112000 | CHANDRA S | 1 | 1 | C | REBECCA Y |  | 0 | 112000 | 11200000 | 100 |  | APP |  |  | 6222A |  |  |  |  |  |  |  |  |  |  |  |  |  |  |  |  | 10-058 |  |  |  |  |  |
| 16222010 |  | CHL Utility Upgrades Contract Progress July 2010 |  | 21d | 2010-07-01 A | 2010-07-30 A | 16222005, 16222007 | 100% |  |  | PROCUREMENT<$50K 60 NO ESCALATION; PROCUREMENT>$50K 69 NO ESCALATION | 59,860 |  | 0 | 59860 | CHANDRA S | 1 | 1 | C | REBECCA Y |  | 0 | 59860 | 5986000 | 100 |  | APP | 08-014 |  | 6222B |  |  |  |  |  |  |  |  |  |  |  |  |  |  |  | 10-021 | 10-058 |  | 10-071 |  |  |  |
| 16222010A |  | CHL Utility Upgrades Contract Progress August 2010 |  | 21d | 2010-07-01 A | 2010-07-30 A | 16222010 FS-36d | 100% |  |  | PROCUREMENT>$50K 69 NO ESCALATION | 112,880 |  | 0 | 112880 | CHANDRA S | 1 | 1 | C | REBECCA Y |  | 0 | 112880 | 11288000 | 100 |  | APP |  |  | 6222B |  |  |  |  |  |  |  |  |  |  |  |  |  |  |  |  |  |  | 10-071 |  |  |  |
| 16222010B |  | CHL Utility Upgrades Contract Progress September 2010 |  | 21d | 2010-07-01 A | 2010-07-30 A | 16222010A FS-58d | 100% |  |  | PROCUREMENT>$50K 69 NO ESCALATION | 87,580 |  | 0 | 87580 | CHANDRA S | 1 | 1 | C | REBECCA Y |  | 0 | 87580 | 8758000 | 100 |  | APP |  |  | 6222B |  |  |  |  |  |  |  |  |  |  |  |  |  |  |  |  |  |  | 10-071 |  |  |  |
| 16222010C |  | CHL Utility Upgrades Contract Progress October 2010 |  | 21d | 2010-07-01 A | 2010-07-30 A | 16222010B FS-79d | 100% |  |  | PROCUREMENT>$50K 69 NO ESCALATION | 83,270 |  | 0 | 83270 | CHANDRA S | 1 | 1 | C | REBECCA Y |  | 0 | 83270 | 8327000 | 100 |  | APP |  |  | 6222B |  |  |  |  |  |  |  |  |  |  |  |  |  |  |  |  |  |  | 10-071 |  |  |  |
| 16222010D |  | CHL Utility Upgrades Contract Progress November 2010 |  | 64d | 2010-07-01 A | 2010-09-30 A | 16222010C FS-100d | 100% |  |  | PROCUREMENT>$50K 69 NO ESCALATION | 505,450 |  | 0 | 505450 | CHANDRA S | 1 | 1 | C | REBECCA Y |  | 0 | 505450 | 50545000 | 100 |  | APP |  |  | 6222B |  |  |  |  |  |  |  |  |  |  |  |  |  |  |  |  |  |  | 10-071 |  |  |  |
| 16222010F |  | CHL Utility Upgrades Contract Progress December 2010 |  | 101d | 2010-07-01 A | 2010-11-22 A | 16222010D FS-120d | 100% |  |  | PROCUREMENT>$50K 69 NO ESCALATION | 609,380 |  | 0 | 609380 | CHANDRA S | 1 | 1 | C | REBECCA Y |  | 0 | 609380 | 60938000 | 100 |  | APP |  |  | 6222B |  |  |  |  |  |  |  |  |  |  |  |  |  |  |  |  |  |  | 10-071 |  |  |  |
| 16222010G |  | CHL Utility Upgrades Contract Progress January 2011 |  | 123d | 2010-07-01 A | 2010-12-31 A | 16222010F FS-137d | 100% |  |  | PROCUREMENT>$50K 69 NO ESCALATION | 413,000 |  | 0 | 413000 | CHANDRA S | 1 | 1 | C | REBECCA Y |  | 0 | 413000 | 41300000 | 100 |  | APP |  |  | 6222B |  |  |  |  |  |  |  |  |  |  |  |  |  |  |  |  |  |  | 10-071 |  |  |  |
| 16222010H |  | CHL Utility Upgrades Contract Progress February 2011 |  | 161d | 2010-07-01 A | 2011-02-28 A | 16222010G FS-157d | 100% |  |  | PROCUREMENT>$50K 69 NO ESCALATION | 175,780 |  | 0 | 175780 | CHANDRA S | 1 | 1 | C | REBECCA Y |  | 0 | 175780 | 17578000 | 100 |  | APP |  |  | 6222B |  |  |  |  |  |  |  |  |  |  |  |  |  |  |  |  |  |  | 10-071 |  |  |  |
| 16222010J |  | CHL Utility Upgrades Contract Progress March 2011 |  | 212d | 2010-07-01 A | 2011-05-10 A | 16222010H FS-176d | 100% |  |  | PROCUREMENT>$50K 69 NO ESCALATION | 124,650 |  | 0 | 124650 | CHANDRA S | 1 | 1 | C | REBECCA Y |  | 0 | 124650 | 12465000 | 100 |  | APP |  |  | 6222B |  |  |  |  |  |  |  |  |  |  |  |  |  |  |  |  |  |  | 10-071 |  |  |  |
| 16222010K |  | CHL Utility Upgrades Contract Progress April 2011 |  | 291d | 2010-07-01 A | 2011-08-31 A | 16222010J FS-199d | 100% |  |  | PROCUREMENT>$50K 69 NO ESCALATION | 65,150 |  | 0 | 65150 | CHANDRA S | 1 | 1 | C | REBECCA Y |  | 0 | 65150 | 6515000 | 100 |  | APP |  |  | 6222B |  |  |  |  |  |  |  |  |  |  |  |  |  |  |  |  |  |  | 10-071 |  |  |  |
| 16222015 |  | CHL Utility Upgrades Mngmnt FY10 |  | 224.88d | 2010-07-01 A | 2011-05-27 A | 16222005 | 100% |  |  | MECH ENG [276.5 h]; MECH DES [26.33 h]; MECH TECH [434.96 h]; OFFICE [92.32 h]; ELEC ENG [59.79 h]; PLANT ENG [13.17 h] | 45,883.36 | 45,939.11 | 0 | 44860.132 | CHANDRA S | 1 | 1 | E | REBECCA Y |  |  |  |  |  |  |  |  |  |  | 100 | 100 | 07-029 |  |  |  |  |  |  |  |  |  |  |  |  | 10-021 | 10-058 |  |  | 833.333333 | -733.333333 | 11-001 |
| 16222015a |  | CHL Utility Upgrades Mngmnt FY11 |  | 225d | 2010-07-01 A | 2011-05-27 A | 16222015 FS-161d | 100% |  |  | PLANT ENG [26.83 h]; MECH ENG [563.5 h]; MECH DES [53.67 h]; MECH TECH [886.45 h]; OFFICE [188.15 h]; ELEC ENG [121.86 h] | 93,510.63 | 93,510.63 | 0 | 94339.7575 | CHANDRA S | 1 | 1 | E | REBECCA Y |  |  |  |  |  |  |  |  |  |  | 100 | 100 | 07-029 |  |  |  |  |  |  |  |  |  |  |  |  | 10-021 | 10-058 |  |  | 833.333333 | -733.333333 | 11-001 |
| 16222020 |  | CHL Utility Upgrades A/E Supprt |  | 221d | 2010-07-01 A | 2011-05-23 A | 16222005 | 100% |  |  | PROCUREMENT<$50K 60 NO ESCALATION FY11 | 28,000 |  | 0 | 28000 | CHANDRA S | 1 | 1 | C | REBECCA Y |  | 0 | 28000 | 2800000 | 100 |  | APP |  | 08-016 |  |  |  |  |  | 09-012 |  |  |  |  |  |  |  |  |  |  | 10-021 | 10-058 |  |  |  |  |  |
| 16222025 |  | CHL Utility Upgrades Cmmssng |  | 189d | 2011-01-03 A | 2011-09-30 A | 16222010K FS-60d, 16222009 FS-60d | 100% | 2011-01-04 | 2011-09-30 | PROCUREMENT<$50K 60 | 16,383.94 |  | 0 | 16383.94 | CHANDRA S | 1 | 1 | C | REBECCA Y |  | 0 | 16383.94 | 1638394 | 100 |  | APP |  |  |  |  |  |  |  |  |  |  |  |  |  |  |  |  |  |  | 10-021 | 10-058 |  |  |  |  |  |
| 16222030 |  | CHL Utility Upgrades Beneficial Occupancy |  | 8d | 2011-10-01 A | 2011-10-12 A | 16222025 | 100% | 2011-10-03 | 2011-10-12 | MECH ENG [80 h] | 5,609.6 | 5,609.6 | 0 | 5436 | CHANDRA S | 1 | 1 | C | REBECCA Y |  |  |  |  |  |  |  |  |  |  |  |  |  |  |  |  |  |  |  |  |  |  |  |  |  | 10-021 | 10-058 |  |  |  |  |  |
| 16222035M |  | CHL Utility Upgrades Complete | milestone | 0d | 2011-10-12 A | 2011-10-12 A | 16222030 FS+10d, 16222020, 16223007, 16222032, 16222015a, 16223005 | 100% | 2011-11-22 | 2011-11-22 |  |  |  |  | 0 | CHANDRA S | 1 | 1 | M | REBECCA Y |  |  |  |  |  |  |  |  |  |  |  |  |  |  |  |  |  |  |  |  |  |  |  |  |  | 10-021 | 10-058 | 6 |  |  |  |  |

Notes:
- 1621020: Explanation: Percent Complete Based on 1621010 / Percent Complete
- 16222000M: Entry Criteria: Predecessor 1242040M (CHL Design / Completed)

| ID | WBS | Activity | Type | Duration | Start | Finish | Predecessors | Complete | Planned start | Planned finish | Resources | Cost | Actual cost | Remaining Material Cost Based on % Compl | Claimed Material Cost Based on % Complet | Initial Claimed Material Calc | Claimed Material Divider | Calculated Remaining Total Cost | MONTHLY EV COST | RESP - Responsibility | STRT%COMP for CM EVM | FNSH%COMP for CM EVM | Advance Purchase Plan > 500K | EVMS Reporting Codes | CAM RESPONSIBLE | 12 GEV MAJOR PROCUREMENT CATAGORY | CR 10-021 | CR 10-058 | Milestone Level | 12 GeV 3rd level Critical Path | CIVIL CRITICAL MILESTONES | CR 08-017 | CR 08-023 | CR 09-010 | CR 09-007 | CR 09-012 | CR 10-042 | CR 10-061 | LOE Divider | LOE Multiplier | CR 07-029 | CR 08-016 | CR 09-011 | CR 10-001 | CR 12-015 | HALL D Related Milestones | Notebook Entry for S | CR 08-034 | Activities with Steps | CR 07-024 | CR 08-014 | CR 08-055 | CR 09-010A | CR 09-038 | CR 09-044 | CR 10-051 | ReBaseline Actuals Adjustment |
| --- | --- | --- | --- | --- | --- | --- | --- | --- | --- | --- | --- | --- | --- | --- | --- | --- | --- | --- | --- | --- | --- | --- | --- | --- | --- | --- | --- | --- | --- | --- | --- | --- | --- | --- | --- | --- | --- | --- | --- | --- | --- | --- | --- | --- | --- | --- | --- | --- | --- | --- | --- | --- | --- | --- | --- | --- | --- |
|  | 3 | **1.6.2.2.3 COOLING WATER** |  |  | 2010-02-01 | 2010-06-01 |  |  |  |  |  |  |  |  |  |  |  |  |  |  |  |  |  |  |  |  |  |  |  |  |  |  |  |  |  |  |  |  |  |  |  |  |  |  |  |  |  |  |  |  |  |  |  |  |  |  |  |
| 16223007 |  | Cooling Water Tower Original Labor |  | 2d | 2010-02-01 A | 2010-02-02 A | 16223000M | 100% |  |  | MECH ENG [80 h]; PROCUREMENT>$50K 69 | 147,122.2 | 5,268 | 0 | 141854.2 | 14185420 | 100 | 0 | 147122.2 | CHANDRA S | 1 | 1 | APP | C | REBECCA Y | 6223 | 10-021 | 10-058 |  |  |  |  |  |  |  |  |  |  |  |  |  |  |  |  |  |  |  |  |  |  |  |  |  |  |  |  |  |
| 16223008 |  | Reverse Entry per CR10-021 P6 5% Spread Fix |  | 2d | 2010-02-01 A | 2010-02-02 A | 9-100M FS+80d | 100% |  |  | PROCUREMENT>$50K 69 | -141,854.2 |  |  |  |  | 100 |  |  | CHANDRA S | 1 | 1 | APP | C | REBECCA Y | 6223 | 10-021 |  |  |  |  |  |  |  |  |  |  |  |  |  |  |  |  |  |  |  |  |  |  |  |  |  |  |  |  |  |  |
| 16223000M |  | Cooling Water Tower Post Solicitation | milestone | 0d | 2010-03-25 A | 2010-03-25 A | 16222000 FS-130d, 9-100M FS+120d | 100% | 2010-04-01 | 2010-04-01 |  |  |  |  |  |  |  |  | 0 | CHANDRA S | 1 | 1 |  | M | REBECCA Y |  | 10-021 | 10-058 | 6 |  |  |  |  |  |  |  |  |  |  |  |  |  |  |  |  |  |  |  |  |  |  |  |  |  |  |  |  |
| 16223005 |  | Cooling Water Tower Award Contract |  | 48d | 2010-03-25 A | 2010-06-01 A | 16223000M | 100% |  |  | MECH ENG [40 h] | 2,634 | 2,634 |  |  |  |  | 0 | 2634 | CHANDRA S | 1 | 1 |  | H | REBECCA Y |  | 10-021 | 10-058 |  |  |  |  |  |  |  |  |  |  |  |  |  |  |  |  |  |  |  |  |  |  |  |  |  |  |  |  |  |
|  | 4 | **1.6.2.2.4** |  |  |  |  |  |  |  |  |  |  |  |  |  |  |  |  |  |  |  |  |  |  |  |  |  |  |  |  |  |  |  |  |  |  |  |  |  |  |  |  |  |  |  |  |  |  |  |  |  |  |  |  |  |  |  |
|  | 5 | **1.6.2.2.5** |  |  |  |  |  |  |  |  |  |  |  |  |  |  |  |  |  |  |  |  |  |  |  |  |  |  |  |  |  |  |  |  |  |  |  |  |  |  |  |  |  |  |  |  |  |  |  |  |  |  |  |  |  |  |  |
|  | 6 | **1.6.2.2.6** |  |  |  |  |  |  |  |  |  |  |  |  |  |  |  |  |  |  |  |  |  |  |  |  |  |  |  |  |  |  |  |  |  |  |  |  |  |  |  |  |  |  |  |  |  |  |  |  |  |  |  |  |  |  |  |
|  | 7 | **1.6.2.2.7** |  |  |  |  |  |  |  |  |  |  |  |  |  |  |  |  |  |  |  |  |  |  |  |  |  |  |  |  |  |  |  |  |  |  |  |  |  |  |  |  |  |  |  |  |  |  |  |  |  |  |  |  |  |  |  |
|  | 3 | **1.6.3 HALL D** |  |  | 2007-10-01 | 2013-08-30 |  |  |  |  |  |  |  |  |  |  |  |  |  |  |  |  |  |  |  |  |  |  |  |  |  |  |  |  |  |  |  |  |  |  |  |  |  |  |  |  |  |  |  |  |  |  |  |  |  |  |  |
|  | 1 | **1.6.3.1 TUNNEL & BUILDINGS** |  |  |  |  |  |  |  |  |  |  |  |  |  |  |  |  |  |  |  |  |  |  |  |  |  |  |  |  |  |  |  |  |  |  |  |  |  |  |  |  |  |  |  |  |  |  |  |  |  |  |  |  |  |  |  |
|  | 1 | **1.6.3.1.1 HALL D** |  |  |  |  |  |  |  |  |  |  |  |  |  |  |  |  |  |  |  |  |  |  |  |  |  |  |  |  |  |  |  |  |  |  |  |  |  |  |  |  |  |  |  |  |  |  |  |  |  |  |  |  |  |  |  |
|  | 2 | **1.6.3.1.2 TUNNEL EXTENSION** |  |  |  |  |  |  |  |  |  |  |  |  |  |  |  |  |  |  |  |  |  |  |  |  |  |  |  |  |  |  |  |  |  |  |  |  |  |  |  |  |  |  |  |  |  |  |  |  |  |  |  |  |  |  |  |
|  | 3 | **1.6.3.1.3 COUNTING HOUSE** |  |  |  |  |  |  |  |  |  |  |  |  |  |  |  |  |  |  |  |  |  |  |  |  |  |  |  |  |  |  |  |  |  |  |  |  |  |  |  |  |  |  |  |  |  |  |  |  |  |  |  |  |  |  |  |
|  | 4 | **1.6.3.1.4 TAGGER AREA** |  |  |  |  |  |  |  |  |  |  |  |  |  |  |  |  |  |  |  |  |  |  |  |  |  |  |  |  |  |  |  |  |  |  |  |  |  |  |  |  |  |  |  |  |  |  |  |  |  |  |  |  |  |  |  |
|  | 5 | **1.6.3.1.5 SERVICE BUILDINGS** |  |  |  |  |  |  |  |  |  |  |  |  |  |  |  |  |  |  |  |  |  |  |  |  |  |  |  |  |  |  |  |  |  |  |  |  |  |  |  |  |  |  |  |  |  |  |  |  |  |  |  |  |  |  |  |
|  | 6 | **1.6.3.1.6 CRYO PLANT** |  |  |  |  |  |  |  |  |  |  |  |  |  |  |  |  |  |  |  |  |  |  |  |  |  |  |  |  |  |  |  |  |  |  |  |  |  |  |  |  |  |  |  |  |  |  |  |  |  |  |  |  |  |  |  |
|  | 7 | **1.6.3.1.7 BEAM DUMP** |  |  |  |  |  |  |  |  |  |  |  |  |  |  |  |  |  |  |  |  |  |  |  |  |  |  |  |  |  |  |  |  |  |  |  |  |  |  |  |  |  |  |  |  |  |  |  |  |  |  |  |  |  |  |  |
|  | 2 | **1.6.3.2 SITEWORK** |  |  |  |  |  |  |  |  |  |  |  |  |  |  |  |  |  |  |  |  |  |  |  |  |  |  |  |  |  |  |  |  |  |  |  |  |  |  |  |  |  |  |  |  |  |  |  |  |  |  |  |  |  |  |  |
|  | 1 | **1.6.3.2.1 CIVIL UTILITIES** |  |  |  |  |  |  |  |  |  |  |  |  |  |  |  |  |  |  |  |  |  |  |  |  |  |  |  |  |  |  |  |  |  |  |  |  |  |  |  |  |  |  |  |  |  |  |  |  |  |  |  |  |  |  |  |
|  | 2 | **1.6.3.2.2 ELECTRICAL UTILITIES** |  |  |  |  |  |  |  |  |  |  |  |  |  |  |  |  |  |  |  |  |  |  |  |  |  |  |  |  |  |  |  |  |  |  |  |  |  |  |  |  |  |  |  |  |  |  |  |  |  |  |  |  |  |  |  |
|  | 3 | **1.6.3.2.3 COOLING WATER** |  |  |  |  |  |  |  |  |  |  |  |  |  |  |  |  |  |  |  |  |  |  |  |  |  |  |  |  |  |  |  |  |  |  |  |  |  |  |  |  |  |  |  |  |  |  |  |  |  |  |  |  |  |  |  |
|  | 4 | **1.6.3.2.4** |  |  |  |  |  |  |  |  |  |  |  |  |  |  |  |  |  |  |  |  |  |  |  |  |  |  |  |  |  |  |  |  |  |  |  |  |  |  |  |  |  |  |  |  |  |  |  |  |  |  |  |  |  |  |  |
|  | 5 | **1.6.3.2.5 SITE PREP, ROADS, & PARKING** |  |  |  |  |  |  |  |  |  |  |  |  |  |  |  |  |  |  |  |  |  |  |  |  |  |  |  |  |  |  |  |  |  |  |  |  |  |  |  |  |  |  |  |  |  |  |  |  |  |  |  |  |  |  |  |
|  | 6 | **1.6.3.2.6** |  |  |  |  |  |  |  |  |  |  |  |  |  |  |  |  |  |  |  |  |  |  |  |  |  |  |  |  |  |  |  |  |  |  |  |  |  |  |  |  |  |  |  |  |  |  |  |  |  |  |  |  |  |  |  |
|  | 7 | **1.6.3.2.7** |  |  |  |  |  |  |  |  |  |  |  |  |  |  |  |  |  |  |  |  |  |  |  |  |  |  |  |  |  |  |  |  |  |  |  |  |  |  |  |  |  |  |  |  |  |  |  |  |  |  |  |  |  |  |  |
|  | 8 | **1.6.3.2.8** |  |  |  |  |  |  |  |  |  |  |  |  |  |  |  |  |  |  |  |  |  |  |  |  |  |  |  |  |  |  |  |  |  |  |  |  |  |  |  |  |  |  |  |  |  |  |  |  |  |  |  |  |  |  |  |
|  | 9 | **1.6.3.2.9** |  |  |  |  |  |  |  |  |  |  |  |  |  |  |  |  |  |  |  |  |  |  |  |  |  |  |  |  |  |  |  |  |  |  |  |  |  |  |  |  |  |  |  |  |  |  |  |  |  |  |  |  |  |  |  |
|  | 3 | **1.6.3.3 CONSTRUCTION** |  |  | 2007-10-01 | 2013-08-30 |  |  |  |  |  |  |  |  |  |  |  |  |  |  |  |  |  |  |  |  |  |  |  |  |  |  |  |  |  |  |  |  |  |  |  |  |  |  |  |  |  |  |  |  |  |  |  |  |  |  |  |
|  | 1 | **1.6.3.3.1 PHASE 1** |  |  | 2007-10-01 | 2013-08-30 |  |  |  |  |  |  |  |  |  |  |  |  |  |  |  |  |  |  |  |  |  |  |  |  |  |  |  |  |  |  |  |  |  |  |  |  |  |  |  |  |  |  |  |  |  |  |  |  |  |  |  |
| 16331005 |  | H-D Complex P- I Award Contract (BONDS) |  | 336d | 2007-10-01 A | 2009-02-12 A | 16331000M, 1243050b, 1243050, 1243045 FS-40d, 1243055 | 100% |  |  | PROCUREMENT<$50K 60; PROCUREMENT>$50K 69 | 125,000 |  | 0 | 125000 | 12500000 | 100 | 0 | 125000 | YASKY R | 1 | 1 |  | C | REBECCA Y |  |  |  |  | 3 | CVL | 08-017 | 08-023 | 09-010 | 09-007 | 09-012 | 10-042 | 10-061 |  |  |  |  |  |  |  |  |  |  |  |  |  |  |  |  |  |  |  |
| 16331020 |  | H-D Complex P- I Constrctn Mngmnt Labor FY09 |  | 187d | 2009-01-05 A | 2009-09-30 A | 16331005 | 100% | 2009-01-05 | 2009-09-29 | MECH TECH [541.94 h]; OFFICE [65.03 h]; ELEC ENG [43.35 h]; MECH ENG [21.68 h]; MECH DES [43.35 h]; PLANT ENG [173.42 h] | 40,765.92 | 41,329.43 |  |  |  |  | 0 | 40765.9283 | YASKY R | 1 | 1 | APP | E | REBECCA Y | 631A |  |  |  |  |  |  |  | 09-010 | 09-007 | 09-012 |  |  | 100 | 100 | 07-029 | 08-016 | 09-011 | 10-001B | 12-015 |  |  |  |  |  |  |  |  |  |  |  |  |
| 16331020c |  | H-D Complex P- I Constrctn Mngmnt Procurement |  | 330d | 2009-01-05 A | 2010-04-30 A | 16331005 | 100% |  |  | PROCUREMENT<$50K 60 NO ESCALATION; PROCUREMENT>$50K 69 NO ESCALATION | 502,815 |  | 0 | 502815 | 50281500 | 100 | 0 | 502815 | YASKY R | 1 | 1 | APP | E | REBECCA Y | 631A |  |  |  |  |  |  |  |  |  |  |  |  | 100 | 100 |  |  |  | 10-001B | 12-015 |  |  |  |  |  |  |  |  |  |  |  |  |
| 16331000M |  | H-D Complex P- I Begin Constr | milestone | 0d | 2009-01-21 A | 2009-01-21 A | 9-090M FS+79d | 100% | 2009-02-02 | 2009-02-02 |  |  |  |  |  |  |  |  | 0 | YASKY R | 1 | 1 |  | M | REBECCA Y |  |  |  | 6 | 3 | CVL |  | 08-023 | 09-010 | 09-007 |  | 10-042 | 10-061 |  |  |  |  |  |  |  | D |  |  |  |  |  |  |  |  |  |  |  |
| 16331025 |  | H-D Complex P- I A-E Constrctn Supprt |  | 466d | 2009-02-11 A | 2010-12-28 A | 16331005 | 100% | 2009-02-11 | 2010-12-21 | PROCUREMENT<$50K 60 NO ESCALATION | 100,907.44 |  | 0 | 100907.44 | 10090744 | 100 | 0 | 100907.44 | YASKY R | 1 | 1 | APP | S | REBECCA Y | 631B |  |  |  |  |  |  |  | 09-010 | 09-007 | 09-012 |  |  |  |  |  | 08-016 |  | 10-001A | 12-015 |  | Notebook Entry for S | 08-034 | NB |  |  |  |  |  |  |  |  |
| 16331010 |  | H-D Complex P- I Constrctn Contract Progress August 09 |  | 50d | 2009-08-06 A | 2009-10-15 A | 9-090M FS+80d, 16331005, 3C-03M | 100% |  |  | PROCUREMENT<$50K 60; PROCUREMENT>$50K 69 | 987,758.73 |  | 0 | 987758.73 | 98775873 | 100 | 0 | 987758.73 | YASKY R | 1 | 1 | APP | C | REBECCA Y | 631B |  |  |  |  |  |  | 08-023 | 09-010 | 09-007 | 09-012 | 10-042 | 10-061 |  |  |  | 08-016 |  |  |  |  |  |  |  | 07-024 | 08-014 | 08-055 | 09-010A | 09-038 | 09-044 | 10-051 |  |
| 16331010A |  | H-D Complex P- I Constrctn Contract Progress September 09 |  | 80d | 2009-08-06 A | 2009-11-30 A | 9-090M FS+80d, 16331010 FS-61d | 100% |  |  | PROCUREMENT>$50K 69 | 216,955 |  | 0 | 216955 | 21695500 | 100 | 0 | 216955 | YASKY R | 1 | 1 | APP | C | REBECCA Y | 631B |  |  |  |  |  |  |  |  |  |  | 10-042 | 10-061 |  |  |  |  |  |  |  |  |  |  |  |  |  |  | 09-010A |  | 09-044 | 10-051 |  |
| 16331010B |  | H-D Complex P- I Constrctn Contract Progress October 09 |  | 117d | 2009-08-06 A | 2010-01-29 A | 16331010A FS-80d | 100% |  |  | PROCUREMENT>$50K 69 NO ESCALATION | 300,399.8 |  | 0 | 300399.8 | 30039980 | 100 | 0 | 300399.8 | YASKY R | 1 | 1 | APP | C | REBECCA Y | 631B |  |  |  |  |  |  |  |  |  |  | 10-042 | 10-061 |  |  |  |  |  | 10-001A |  |  |  |  |  |  |  |  | 09-010A |  | 09-044 | 10-051 |  |
| 16331010C |  | H-D Complex P- I Constrctn Contract Progress November 09 |  | 136d | 2009-08-06 A | 2010-02-26 A | 16331010B FS-99d | 100% |  |  | PROCUREMENT>$50K 69 NO ESCALATION | 508,966.2 |  | 0 | 508966.2 | 50896620 | 100 | 0 | 508966.2 | YASKY R | 1 | 1 | APP | C | REBECCA Y | 631B |  |  |  |  |  |  |  |  |  |  | 10-042 | 10-061 |  |  |  |  |  | 10-001A |  |  |  |  |  |  |  |  | 09-010A |  | 09-044 | 10-051 |  |
| 16331010D |  | H-D Complex P- I Constrctn Contract Progress December 09 |  | 159d | 2009-08-06 A | 2010-03-31 A | 16331010C FS-118d | 100% |  |  | PROCUREMENT>$50K 69 NO ESCALATION | 799,325.41 |  | 0 | 799325.41 | 79932541 | 100 | 0 | 799325.41 | YASKY R | 1 | 1 | APP | C | REBECCA Y | 631B |  |  |  |  |  |  |  |  |  |  | 10-042 | 10-061 |  |  |  |  |  | 10-001A |  |  |  |  |  |  |  |  | 09-010A |  | 09-044 | 10-051 |  |
| 16331010F |  | H-D Complex P- I Constrctn Contract Progress January 10 |  | 177d | 2009-08-06 A | 2010-04-26 A | 16331010D FS-141d | 100% |  |  | PROCUREMENT>$50K 69 NO ESCALATION | 633,143.25 |  | 0 | 633143.25 | 63314325 | 100 | 0 | 633143.25 | YASKY R | 1 | 1 | APP | C | REBECCA Y | 631B |  |  |  |  |  |  |  |  |  |  | 10-042 | 10-061 |  |  |  |  |  | 10-001A |  |  |  |  |  |  |  |  | 09-010A |  | 09-044 | 10-051 |  |
| 16331010G |  | H-D Complex P- I Constrctn Contract Progress February 10 |  | 187d | 2009-08-06 A | 2010-05-10 A | 16331010F FS-163d | 100% |  |  | PROCUREMENT>$50K 69 NO ESCALATION | 229,811 |  | 0 | 229811 | 22981100 | 100 | 0 | 229811 | YASKY R | 1 | 1 | APP | C | REBECCA Y | 631B |  |  |  |  |  |  |  |  |  |  | 10-042 | 10-061 |  |  |  |  |  | 10-001A |  |  |  |  |  |  |  |  | 09-010A |  | 09-044 | 10-051 |  |
| 16331010H |  | H-D Complex P- I Constrctn Contract Progress March 10 |  | 192d | 2009-08-06 A | 2010-05-17 A | 16331010G FS-183d | 100% |  |  | PROCUREMENT>$50K 69 NO ESCALATION | 393,348 |  | 0 | 393348 | 39334800 | 100 | 0 | 393348 | YASKY R | 1 | 1 | APP | C | REBECCA Y | 631B |  |  |  |  |  |  |  |  |  |  | 10-042 | 10-061 |  |  |  |  |  | 10-001A |  |  |  |  |  |  |  |  | 09-010A |  | 09-044 | 10-051 |  |
| 16331010J |  | H-D Complex P- I Constrctn Contract Progress April 10 |  | 240d | 2009-08-06 A | 2010-07-26 A | 16331010H FS-205d | 100% |  |  | PROCUREMENT>$50K 69 NO ESCALATION | 567,231 |  | 0 | 567231 | 56723100 | 100 | 0 | 567231 | YASKY R | 1 | 1 | APP | C | REBECCA Y | 631B |  |  |  |  |  |  |  |  |  |  | 10-042 | 10-061 |  |  |  |  |  | 10-001A |  |  |  |  |  |  |  |  | 09-010A |  | 09-044 | 10-051 |  |
| 16331010K |  | H-D Complex P- I Constrctn Contract Progress May 10 |  | 266d | 2009-08-06 A | 2010-08-31 A | 16331010J FS-226d | 100% |  |  | PROCUREMENT>$50K 69 NO ESCALATION | 394,533.25 |  | 0 | 394533.25 | 39453325 | 100 | 0 | 394533.25 | YASKY R | 1 | 1 | APP | C | REBECCA Y | 631B |  |  |  |  |  |  |  |  |  |  | 10-042 | 10-061 |  |  |  |  |  | 10-001A |  |  |  |  |  |  |  |  | 09-010A |  | 09-044 | 10-051 |  |
| 16331010L |  | H-D Complex P- I Constrctn Contract Progress June 10 |  | 308d | 2009-08-06 A | 2010-10-29 A | 16331010K FS-248d | 100% |  |  | PROCUREMENT>$50K 69 NO ESCALATION | 595,761 |  | 0 | 595761 | 59576100 | 100 | 0 | 595761 | YASKY R | 1 | 1 | APP | C | REBECCA Y | 631B |  |  |  |  |  |  |  |  |  |  | 10-042 | 10-061 |  |  |  |  |  | 10-001A |  |  |  |  |  |  |  |  | 09-010A |  | 09-044 | 10-051 |  |
| 16331010N |  | H-D Complex P- I Constrctn Contract Progress July 10 Original |  | 308d | 2009-08-06 A | 2010-10-29 A | 16331010L FS-269d | 100% |  |  | PROCUREMENT>$50K 69 NO ESCALATION | 30,023.78 |  | 0 | 30023.78 | 3002378 | 100 | 0 | 30023.78 | YASKY R | 1 | 1 | APP | C | REBECCA Y | 631B |  |  |  |  |  |  |  |  |  |  | 10-042 | 10-061 |  |  |  |  |  | 10-001A |  |  |  |  |  |  |  |  | 09-010A |  | 09-044 | 10-051 |  |
| 16331010N5 |  | H-D Complex P- I Constrctn Contract Progress July 10 Revised Delivery per CR10-061 |  | 308d | 2009-08-06 A | 2010-10-29 A | 9-090M FS+80d | 100% |  |  | PROCUREMENT>$50K 69 NO ESCALATION | 277,719.93 |  | 0 | 277719.93 | 27771993 | 100 | 0 | 277719.93 | YASKY R | 1 | 1 | APP | C | REBECCA Y | 631B |  |  |  |  |  |  |  |  |  |  | 10-042 | 10-061 |  |  |  |  |  | 10-001A |  |  |  |  |  |  |  |  |  |  | 09-044 | 10-051 |  |
| 16331010P |  | H-D Complex P- I Constrctn Contract Progress August 10 |  | 324d | 2009-08-06 A | 2010-11-22 A | 16331010N FS-370d, 16331010N5 FS-370d | 100% |  |  | PROCUREMENT>$50K 69 NO ESCALATION | 277,719.93 |  | 0 | 277719.93 | 27771993 | 100 | 0 | 277719.93 | YASKY R | 1 | 1 | APP | C | REBECCA Y | 631B |  |  |  |  |  |  |  |  |  |  | 10-042 | 10-061 |  |  |  |  |  | 10-001A |  |  |  |  |  |  |  |  |  |  | 09-044 | 10-051 |  |
| 16331010Q |  | H-D Complex P- I Constrctn Contract Progress September 10 |  | 324d | 2009-08-06 A | 2010-11-22 A | 16331010P FS-395d | 100% |  |  | PROCUREMENT>$50K 69 NO ESCALATION | 277,719.93 |  | 0 | 277719.93 | 27771993 | 100 | 0 | 277719.93 | YASKY R | 1 | 1 | APP | C | REBECCA Y | 631B |  |  |  |  |  |  |  |  |  |  | 10-042 | 10-061 |  |  |  |  |  | 10-001A |  |  |  |  |  |  |  |  |  |  | 09-044 | 10-051 |  |
| 16331010R |  | H-D Complex P- I Constrctn Contract Progress October 10 |  | 324d | 2009-08-06 A | 2010-11-22 A | 16331010Q FS-416d | 100% |  |  | PROCUREMENT>$50K 69 NO ESCALATION | 277,719.93 |  | 0 | 277719.93 | 27771993 | 100 | 0 | 277719.93 | YASKY R | 1 | 1 | APP | C | REBECCA Y | 631B |  |  |  |  |  |  |  |  |  |  | 10-042 | 10-061 |  |  |  |  |  | 10-001A |  |  |  |  |  |  |  |  |  |  | 09-044 | 10-051 |  |
| 16331010S |  | H-D Complex P- I Constrctn Contract Progress November 10 |  | 343d | 2009-08-06 A | 2010-12-28 A | 16331010R FS-437d | 100% | 2009-08-06 | 2010-12-21 | PROCUREMENT>$50K 69 NO ESCALATION | 277,719.93 |  | 0 | 277719.93 | 27771993 | 100 | 0 | 277719.93 | YASKY R | 1 | 1 | APP | C | REBECCA Y | 631B |  |  |  |  |  |  |  |  |  |  | 10-042 | 10-061 |  |  |  |  |  | 10-001A |  |  |  |  |  |  |  |  |  |  | 09-044 | 10-051 |  |
| 16331012 |  | H-D Complex P- I ARRA Funds |  | 241d | 2009-08-06 A | 2010-07-27 A | 9-090M FS+209d | 100% |  |  | PROCUREMENT>$50K 69 NO ESCALATION | 37,490.52 |  | 0 | 37490.52 | 3749052 | 100 | 0 | 37490.52 | YASKY R | 1 | 1 | APP | E | REBECCA Y | 631B |  |  |  |  |  |  |  |  |  |  |  |  | 100 | 100 |  |  |  |  | 12-015 |  |  |  |  |  |  |  |  |  | 09-044 |  |  |
| 16331011 |  | H-D Complex P- I Constrctn Contract Modifications |  | 325d | 2009-09-01 A | 2010-12-28 A | 16331005 | 100% | 2009-09-01 | 2010-12-21 | PROCUREMENT>$50K 69 NO ESCALATION FY10; PROCUREMENT>$50K 69 NO ESCALATION; PROCUREMENT>$50K 69 | 354,138.36 |  | 0 | 354138.3552 | 35413835.52 | 100 | 0 | 354138.3552 | YASKY R | 1 | 1 | APP | S | REBECCA Y | 631B |  |  |  |  |  |  | 08-023 | 09-010 | 09-007 |  | 10-042 |  |  |  |  | 08-016 |  |  |  |  | Notebook Entry for S |  | NB | 07-024 | 08-014 | 08-055 | 09-010A |  | 09-044 | 10-051 |  |
| 16331020b |  | H-D Complex P- I Constrctn Mngmnt Labor FY10 |  | 141.07d | 2009-10-01 A | 2010-04-30 A | 16331020 | 100% |  |  | ELEC ENG [36.65 h]; MECH ENG [18.32 h]; MECH DES [36.65 h]; PLANT ENG [146.58 h]; MECH TECH [458.06 h]; OFFICE [54.97 h] | 35,556.27 | 35,613.91 |  |  |  |  | 0 | 35556.2662 | YASKY R | 1 | 1 | APP | E | REBECCA Y | 631A |  |  |  |  |  |  |  |  |  |  |  |  | 100 | 100 |  |  |  | 10-001B | 12-015 |  |  |  |  |  |  |  |  |  |  |  |  |
| 16331013 |  | H-D Complex P- I Floor Slab Contract Modification |  | 22d | 2010-04-01 A | 2010-04-30 A | 9-100M FS+120d | 100% |  |  | PROCUREMENT<$50K 60; PROCUREMENT>$50K 69 NO ESCALATION | 400,000 |  | 0 | 400000 | 40000000 | 100 | 0 | 400000 | YASKY R | 1 | 1 | APP | C | REBECCA Y | 631B |  |  |  |  |  |  |  | 09-010 | 09-007 |  | 10-042 | 10-061 |  |  |  |  |  | 10-001A |  |  |  |  |  |  |  |  |  |  |  | 10-051 |  |
| 16331015 |  | H-D Complex P- I Cmmssng Original |  | 54d | 2010-05-03 A | 2010-07-19 A | 16331010B, 16331010J, 16331010C, 16331010D, 16331010G, 16331013 FS-70d, 16331010F, 16331010K FS-20d, 16331010A, 16331010, 16331010L FS-42d, 16331011 FS-80d, 16331010N FS-90d, 16331010H | 100% |  |  | PROCUREMENT<$50K 60 NO ESCALATION | 23,074.6 |  | 0 | 23074.6 | 2307460 | 100 | 0 | 23074.6 | YASKY R | 1 | 1 | APP | C | REBECCA Y | 631B |  |  |  |  |  |  |  | 09-010 | 09-007 |  | 10-042 | 10-061 |  |  |  |  |  | 10-001A |  |  |  |  |  |  |  |  |  |  |  | 10-051 |  |
| 16331014 |  | H-D Complex P- I Settlement Agreement and Release |  | 16d | 2010-07-01 A | 2010-07-23 A | 9-100M FS+184d | 100% |  |  | PROCUREMENT>$50K 69 NO ESCALATION; PROCUREMENT<$50K 60 | 885,000 |  | 0 | 885000 | 88500000 | 100 | 0 | 885000 | YASKY R | 1 | 1 | APP | P | REBECCA Y | 631B |  |  |  |  |  |  |  | 09-010 | 09-007 |  | 10-042 | 10-061 |  |  |  |  |  | 10-001A |  |  |  |  |  |  |  |  |  |  |  | 10-051 |  |
| 16331017 |  | Reverse Entry Per CR10-061 |  | 17d | 2010-07-01 A | 2010-07-26 A | 9-100M FS+184d | 100% |  |  | PLANT ENG [-4 h]; PROCUREMENT<$50K 60 NO ESCALATION; PROCUREMENT>$50K 69 NO ESCALATION | -53,362.26 | -263.88 |  |  |  | 100 |  |  | YASKY R | 1 | 1 | APP | N/A | REBECCA Y | 631B |  |  |  |  |  |  |  | 09-010 | 09-007 |  | 10-042 | 10-061 |  |  |  |  |  | 10-001A |  |  |  |  |  |  |  |  |  |  |  | 10-051 |  |
| 16331030 |  | H-D Complex P- I Beneficial Occupancy Original |  | 17d | 2010-07-01 A | 2010-07-26 A | 16331010A, 16331010C, 16331010G, 16331010B, 16331010N FS-22d, 16331010D, 16331010J, 16331015 FS-40d, 16331010N5 FS-22d, 16331010H, 16331010K FS-55d, 16331010L FS-75d, 16331010F, 16331010 | 100% |  |  | PLANT ENG [4 h] | 263.88 | 263.88 |  |  |  |  | 0 | 263.88 | YASKY R | 1 | 1 |  | H | REBECCA Y |  |  |  |  | 3 | CVL |  | 08-023 | 09-010 | 09-007 |  | 10-042 | 10-061 |  |  |  |  |  |  |  |  |  |  |  |  |  |  |  |  |  | 10-051 |  |
| 16331016 |  | H-D Complex P- I Cmmssng Revised Date per CR10-061 |  | 50d | 2010-09-14 A | 2010-11-22 A | 16331010B, 16331010C, 16331010K, 16331010R FS-62d, 16331010A, 16331011 FS-60d, 16331010H, 16331014, 16331010D, 16331010F, 16331010L, 16331010G, 16331013, 16331010, 16331010J | 100% |  |  | PROCUREMENT<$50K 60 NO ESCALATION | 23,074.6 |  | 0 | 23074.6 | 2307460 | 100 | 0 | 23074.6 | YASKY R | 1 | 1 | APP | H | REBECCA Y | 631B |  |  |  |  |  |  |  | 09-010 | 09-007 |  | 10-042 | 10-061 |  |  |  |  |  | 10-001A |  |  |  |  |  |  |  |  |  |  |  | 10-051 |  |
| 16331032 |  | H-D Complex P- I Beneficial Occupancy Revised Date per CR10-061 |  | 8d | 2010-12-23 A | 2010-12-28 A | 16331010B, 16331010R FS-10d, 16331010D, 16331010G, 16331010K, 16331010A, 16331010C, 16331010, 16331015 FS-4d, 16331010H, 16331016 FS-4d, 16331010L FS-2d, 16331010F, 16331010J, 16331010S FS-20d | 100% | 2010-12-29 | 2011-01-10 | PLANT ENG [40 h] | 2,722.8 | 2,722.8 |  |  |  |  | 0 | 2722.8 | YASKY R | 1 | 1 |  | H | REBECCA Y |  |  |  |  | 3 | CVL |  | 08-023 | 09-010 | 09-007 |  | 10-042 | 10-061 |  |  |  |  |  |  |  |  |  |  |  |  |  |  |  |  |  | 10-051 |  |
| 16331035M |  | H-D Complex P- I Constr Comp | milestone | 0d | 2010-12-28 A | 2010-12-28 A | 16331020c, 16331032, 16331025, 16331020b, 3C-06M, 16331012, 16331030 | 100% | 2011-01-19 | 2011-01-19 |  |  |  |  |  |  |  |  | 0 | YASKY R | 1 | 1 |  | M | REBECCA Y |  |  |  | 6 |  |  |  |  | 09-010 | 09-007 |  |  | 10-061 |  |  |  |  |  |  | 12-015 | D |  |  |  |  |  |  |  |  |  |  |  |
| 16331040 |  | Re-Baseline Actuals Adjustment |  | 1d | 2013-08-30 A | 2013-08-30 A |  | 100% | 2013-09-03 | 2013-09-03 | PROCUREMENT>$50K 69 NO ESCALATION | 66,963.44 |  | 0 | 66963.44 | 6696344 | 100 |  | 66963.44 |  |  |  |  |  |  |  |  |  |  |  |  |  |  |  |  |  |  |  |  |  |  |  |  |  |  |  |  |  |  |  |  |  |  |  |  |  | ADJ |

Notes:
- 16223000M: Entry Criteria: Predecessor 1242040M (CHL Design / Completed)
- 16331025: Explanation: Percent Complete Based on 16331010 Percent Complete
- 16331011: Explanation: Progress to follow Activity 16331010 Same as / 16331025 PMK 11 January 10

| ID | WBS | Activity | Type | Duration | Start | Finish | Predecessors | Complete | Planned start | Planned finish | Resources | Cost | Actual cost | MONTHLY EV COST | RESP - Responsibility | STRT%COMP for CM EVM | FNSH%COMP for CM EVM | 12 GeV 2nd level Critical Path | CIVIL CRITICAL MILESTONES | CR 08-017 | CR 08-023 | EVMS Reporting Codes | CAM RESPONSIBLE | CR 09-007 | CR 09-012 | CR 09-044 | CR 10-059 | CR 11-004 | CR 11-044 | Remaining Material Cost Based on % Compl | Claimed Material Cost Based on % Complet | Initial Claimed Material Calc | Claimed Material Divider | Calculated Remaining Total Cost | Advance Purchase Plan > 500K | CR 08-014 | CR 08-016 | CR 09-010 | 12 GEV MAJOR PROCUREMENT CATAGORY | CR 10-001 | Milestone Level | HALL D Related Milestones | CR 11-020 | Activities with Steps | LOE % Pre Calc | LOE % | LOE Divider | LOE Multiplier | CR 07-029 | CR 09-011 | CR 11-001 | CR 12-015 | CR 08-034 | CR 10-028 | CR 12-029 | CR 10-019 | CR 08-056 | CR 11-026 | CR 11-047 | CR 12-009 | ReBaseline Actuals Adjustment |
| --- | --- | --- | --- | --- | --- | --- | --- | --- | --- | --- | --- | --- | --- | --- | --- | --- | --- | --- | --- | --- | --- | --- | --- | --- | --- | --- | --- | --- | --- | --- | --- | --- | --- | --- | --- | --- | --- | --- | --- | --- | --- | --- | --- | --- | --- | --- | --- | --- | --- | --- | --- | --- | --- | --- | --- | --- | --- | --- | --- | --- | --- |
|  | 2 | **1.6.3.3.2 PHASE 2** |  |  | 2009-08-06 | 2013-08-30 |  |  |  |  |  |  |  |  |  |  |  |  |  |  |  |  |  |  |  |  |  |  |  |  |  |  |  |  |  |  |  |  |  |  |  |  |  |  |  |  |  |  |  |  |  |  |  |  |  |  |  |  |  |  |  |
| 16332005 |  | H-D Complex P- II Award Contract |  | 1d | 2009-08-06 A | 2009-08-06 A | 9-090M FS+209d | 100% |  |  |  |  |  | 0 | YASKY R | 1 | 1 | 2 | CVL | 08-017 | 08-023 | Z | REBECCA Y | 09-007 | 09-012 | 09-044 | 10-059 | 11-004 | 11-044 |  |  |  |  |  |  |  |  |  |  |  |  |  |  |  |  |  |  |  |  |  |  |  |  |  |  |  |  |  |  |  |  |
| 16332010 |  | H-D Complex P- II Contract Progress June 2010 Progress Payment |  | 223d | 2009-08-06 A | 2010-06-30 A | 16332005 FS-1d | 100% |  |  | PROCUREMENT<$50K 60 NO ESCALATION; PROCUREMENT>$50K 69 NO ESCALATION | 301,352.5 |  | 301352.5 | YASKY R | 1 | 1 |  |  |  |  | C | REBECCA Y | 09-007 | 09-012 | 09-044 | 10-059 | 11-004 | 11-044 | 0 | 301352.5 | 30135250 | 100 | 0 | APP | 08-014 | 08-016 | 09-010 | 631B | 10-001A |  |  |  |  |  |  |  |  |  |  |  |  |  |  |  |  |  |  |  |  |  |
| 16332010B |  | H-D Complex P- II Contract Progress July 2010 Progress Payment |  | 244d | 2009-08-06 A | 2010-07-30 A | 16332010 FS-223d | 100% |  |  | PROCUREMENT>$50K 69 NO ESCALATION | 267,310 |  | 267310 | YASKY R | 1 | 1 |  |  |  |  | C | REBECCA Y |  |  |  | 10-059 | 11-004 | 11-044 | 0 | 267310 | 26731000 | 100 | 0 | APP |  |  |  | 631B |  |  |  |  |  |  |  |  |  |  |  |  |  |  |  |  |  |  |  |  |  |  |
| 16332010C |  | H-D Complex P- II Contract Progress August 2010 Progress Payment |  | 244d | 2009-08-06 A | 2010-07-30 A | 16332010B FS-244d | 100% |  |  | PROCUREMENT>$50K 69 NO ESCALATION | 64,389 |  | 64389 | YASKY R | 1 | 1 |  |  |  |  | C | REBECCA Y |  |  |  | 10-059 | 11-004 | 11-044 | 0 | 64389 | 6438900 | 100 | 0 | APP |  |  |  | 631B |  |  |  |  |  |  |  |  |  |  |  |  |  |  |  |  |  |  |  |  |  |  |
| 16332010D |  | H-D Complex P- II Contract Progress September 2010 Progress Payment |  | 244d | 2009-08-06 A | 2010-07-30 A | 16332010C FS-266d | 100% |  |  | PROCUREMENT>$50K 69 NO ESCALATION | 98,161 |  | 98161 | YASKY R | 1 | 1 |  |  |  |  | C | REBECCA Y |  |  |  | 10-059 | 11-004 | 11-044 | 0 | 98161 | 9816100 | 100 | 0 | APP |  |  |  | 631B |  |  |  |  |  |  |  |  |  |  |  |  |  |  |  |  |  |  |  |  |  |  |
| 16332010F |  | H-D Complex P- II Contract Progress October 2010 Progress Payment |  | 287d | 2009-08-06 A | 2010-09-30 A | 16332010D FS-287d | 100% |  |  | PROCUREMENT>$50K 69 NO ESCALATION | 227,000 |  | 227000 | YASKY R | 1 | 1 |  |  |  |  | C | REBECCA Y |  |  |  | 10-059 | 11-004 | 11-044 | 0 | 227000 | 22700000 | 100 | 0 | APP |  |  |  | 631B |  |  |  |  |  |  |  |  |  |  |  |  |  |  |  |  |  |  |  |  |  |  |
| 16332010G |  | H-D Complex P- II Contract Progress November 2010 Progress Payment |  | 304d | 2009-08-06 A | 2010-10-25 A | 16332010F FS-308d | 100% |  |  | PROCUREMENT>$50K 69 NO ESCALATION | 291,875 |  | 291875 | YASKY R | 1 | 1 |  |  |  |  | C | REBECCA Y |  |  |  | 10-059 | 11-004 | 11-044 | 0 | 291875 | 29187500 | 100 | 0 | APP |  |  |  | 631B |  |  |  |  |  |  |  |  |  |  |  |  |  |  |  |  |  |  |  |  |  |  |
| 16332010H |  | H-D Complex P- II Contract Progress December 2010 Progress Payment |  | 304d | 2009-08-06 A | 2010-10-25 A | 16332010G FS-328d | 100% |  |  | PROCUREMENT>$50K 69 NO ESCALATION | 289,502 |  | 289502 | YASKY R | 1 | 1 |  |  |  |  | C | REBECCA Y |  |  |  | 10-059 | 11-004 | 11-044 | 0 | 289502 | 28950200 | 100 | 0 | APP |  |  |  | 631B |  |  |  |  |  |  |  |  |  |  |  |  |  |  |  |  |  |  |  |  |  |  |
| 16332010J |  | H-D Complex P- II Contract Progress January 2011 Progress Payment |  | 324d | 2009-08-06 A | 2010-11-22 A | 16332010H FS-345d | 100% |  |  | PROCUREMENT>$50K 69 NO ESCALATION | 127,700 |  | 127700 | YASKY R | 1 | 1 |  |  |  |  | C | REBECCA Y |  |  |  | 10-059 | 11-004 | 11-044 | 0 | 127700 | 12770000 | 100 | 0 | APP |  |  |  | 631B |  |  |  |  |  |  |  |  |  |  |  |  |  |  |  |  |  |  |  |  |  |  |
| 16332010K |  | H-D Complex P- II Contract Progress February 2011 Progress Payment |  | 324d | 2009-08-06 A | 2010-11-22 A | 16332010J FS-365d | 100% |  |  | PROCUREMENT>$50K 69 NO ESCALATION | 192,348 |  | 192348 | YASKY R | 1 | 1 |  |  |  |  | C | REBECCA Y |  |  |  | 10-059 | 11-004 | 11-044 | 0 | 192348 | 19234800 | 100 | 0 | APP |  |  |  | 631B |  |  |  |  |  |  |  |  |  |  |  |  |  |  |  |  |  |  |  |  |  |  |
| 16332010N |  | H-D Complex P- II Contract Progress March 2011 Progress Payment |  | 346d | 2009-08-06 A | 2010-12-31 A | 16332010K FS-384d | 100% |  |  | PROCUREMENT>$50K 69 NO ESCALATION | 195,771 |  | 195771 | YASKY R | 1 | 1 |  |  |  |  | C | REBECCA Y |  |  |  | 10-059 | 11-004 | 11-044 | 0 | 195771 | 19577100 | 100 | 0 | APP |  |  |  | 631B |  |  |  |  |  |  |  |  |  |  |  |  |  |  |  |  |  |  |  |  |  |  |
| 16332010P |  | H-D Complex P- II Contract Progress April 2011 Progress Payment |  | 383d | 2009-08-06 A | 2011-02-25 A | 16332010N FS-407d | 100% |  |  | PROCUREMENT>$50K 69 NO ESCALATION | 206,551 |  | 206551 | YASKY R | 1 | 1 |  |  |  |  | C | REBECCA Y |  |  |  | 10-059 | 11-004 | 11-044 | 0 | 206551 | 20655100 | 100 | 0 | APP |  |  |  | 631B |  |  |  |  |  |  |  |  |  |  |  |  |  |  |  |  |  |  |  |  |  |  |
| 16332010Q |  | H-D Complex P- II Contract Progress May 2011 Progress Payment |  | 444d | 2009-08-06 A | 2011-05-23 A | 16332010P FS-428d | 100% |  |  | PROCUREMENT>$50K 69 NO ESCALATION | 800,206 |  | 800206 | YASKY R | 1 | 1 |  |  |  |  | C | REBECCA Y |  |  |  | 10-059 | 11-004 | 11-044 | 0 | 800206 | 80020600 | 100 | 0 | APP |  |  |  | 631B |  |  |  |  |  |  |  |  |  |  |  |  |  |  |  |  |  |  |  |  |  |  |
| 16332010R |  | H-D Complex P- II Contract Progress June 2011 Progress Payment |  | 449d | 2009-08-06 A | 2011-05-31 A | 16332010Q FS-449d | 100% |  |  | PROCUREMENT>$50K 69 NO ESCALATION | 199,024 |  | 199024 | YASKY R | 1 | 1 |  |  |  |  | C | REBECCA Y |  |  |  | 10-059 | 11-004 | 11-044 | 0 | 199024 | 19902400 | 100 | 0 | APP |  |  |  | 631B |  |  |  |  |  |  |  |  |  |  |  |  |  |  |  |  |  |  |  |  |  |  |
| 16332010S |  | H-D Complex P- II Contract Progress July 2011 Progress Payment |  | 491d | 2009-08-06 A | 2011-07-29 A | 16332010R FS-471d | 100% |  |  | PROCUREMENT>$50K 69 NO ESCALATION | 734,054 |  | 734054 | YASKY R | 1 | 1 |  |  |  |  | C | REBECCA Y |  |  |  | 10-059 | 11-004 | 11-044 | 0 | 734054 | 73405400 | 100 | 0 | APP |  |  |  | 631B |  |  |  |  |  |  |  |  |  |  |  |  |  |  |  |  |  |  |  |  |  |  |
| 16332010T |  | H-D Complex P- II Contract Progress August 2011 Progress Payment |  | 513d | 2009-08-06 A | 2011-08-30 A | 16332010S FS-491d | 100% |  |  | PROCUREMENT>$50K 69 NO ESCALATION | 734,054 |  | 734054 | YASKY R | 1 | 1 |  |  |  |  | C | REBECCA Y |  |  |  | 10-059 | 11-004 | 11-044 | 0 | 734054 | 73405400 | 100 | 0 | APP |  |  |  | 631B |  |  |  |  |  |  |  |  |  |  |  |  |  |  |  |  |  |  |  |  |  |  |
| 16332010U |  | H-D Complex P- II Contract Progress September 2011 Progress Payment |  | 550d | 2009-08-06 A | 2011-10-21 A | 16332010T FS-514d | 100% |  |  | PROCUREMENT>$50K 69 NO ESCALATION | 734,054 |  | 734054 | YASKY R | 1 | 1 |  |  |  |  | C | REBECCA Y |  |  |  | 10-059 | 11-004 | 11-044 | 0 | 734054 | 73405400 | 100 | 0 | APP |  |  |  | 631B |  |  |  |  |  |  |  |  |  |  |  |  |  |  |  |  |  |  |  |  |  |  |
| 16332010V |  | H-D Complex P- II Contract Progress October 2011 Progress Payment |  | 613d | 2009-08-06 A | 2012-01-31 A | 16332010U FS-535d | 100% |  |  | PROCUREMENT>$50K 69 NO ESCALATION | 734,054.75 |  | 734054.75 | YASKY R | 1 | 1 |  |  |  |  | C | REBECCA Y |  |  |  | 10-059 | 11-004 | 11-044 | 0 | 734054.75 | 73405475 | 100 | 0 | APP |  |  |  | 631B |  |  |  |  |  |  |  |  |  |  |  |  |  |  |  |  |  |  |  |  |  |  |
| 16332000M |  | H-D Complex P- II Begin Constr | milestone | 0d | 2010-01-22 A | 2010-01-22 A | 9-100M FS+108d | 100% | 2010-03-16 | 2010-03-16 |  |  |  | 0 | YASKY R | 1 | 1 | 2 | CVL |  | 08-023 | M | REBECCA Y | 09-007 |  |  | 10-059 |  |  |  |  |  |  |  |  |  |  |  |  |  | 6 | D | 11-020 |  |  |  |  |  |  |  |  |  |  |  |  |  |  |  |  |  |  |
| 16332008 |  | H-D Complex P- II Notice to Proceed |  | 6d | 2010-01-22 A | 2010-01-29 A | 16332000M | 100% |  |  |  |  |  | 0 | YASKY R | 1 | 1 | 2 | CVL |  |  | Z | REBECCA Y |  |  | 09-044 | 10-059 |  |  |  |  |  |  |  |  |  |  |  |  |  |  |  |  |  |  |  |  |  |  |  |  |  |  |  |  |  |  |  |  |  |  |
| 16332011 |  | H-D Complex & Cryo Plant P- II Contract Modifications |  | 440d | 2010-02-03 A | 2011-11-03 A | 16332008 | 100% |  |  | PROCUREMENT>$50K 69 NO ESCALATION | 310,715.82 |  | 310715.82 | YASKY R | 1 | 1 |  |  |  |  | S | REBECCA Y | 09-007 |  |  |  | 11-004 |  | 0 | 310715.82 | 31071582 | 100 | 0 | APP | 08-014 | 08-016 | 09-010 | 631B | 10-001A |  |  |  | NB |  |  |  |  |  |  |  |  |  |  |  |  |  |  |  |  |  |
| 16332012 |  | H-D Complex P- II ARRA Funds |  | 300d | 2010-02-03 A | 2011-04-18 A | 16332008 | 100% |  |  | PROCUREMENT<$50K 60 NO ESCALATION | 64,312.3 |  | 64312.3 | YASKY R | 1 | 1 |  |  |  |  | E | REBECCA Y |  |  | 09-044 |  | 11-004 |  | 0 | 64312.3 | 6431230 | 100 | 0 | APP |  |  |  | 631B | 10-001A |  |  |  |  | 40000 | -39900 | 100 | 100 |  |  |  |  |  |  |  |  |  |  |  |  |  |
| 16332020 |  | H-D Complex P- II Constrctn Mngmnt Labor FY10 |  | 379.23d | 2010-02-03 A | 2011-08-10 A | 16332008 | 100% |  |  | MECH ENG [123.79 h]; MECH TECH [442.11 h]; MECH DES [123.79 h]; PLANT ENG [194.53 h]; OFFICE [88.42 h]; ELEC ENG [53.05 h] | 51,828.65 | 51,871.13 | 50924.8103 | YASKY R | 1 | 1 |  |  |  |  | E | REBECCA Y | 09-007 | 09-012 |  |  |  |  |  |  |  |  | 0 | APP |  | 08-016 |  | 631A | 10-001A |  |  |  |  | 2.10526315 | 97.89473684 | 100 | 100 | 07-029 | 09-011 | 11-001 | 12-015 |  |  |  |  |  |  |  |  |  |
| 16332020b |  | H-D Complex P- II Constrctn Mngmnt Labor FY11 |  | 379.09d | 2010-02-03 A | 2011-08-10 A | 16332020 FS-212d | 100% |  |  | MECH ENG [156.21 h]; MECH TECH [557.89 h]; MECH DES [156.21 h]; PLANT ENG [245.47 h]; OFFICE [111.58 h]; ELEC ENG [66.95 h] | 65,401.79 | 65,455.47 | 66309.2771 | YASKY R | 1 | 1 |  |  |  |  | E | REBECCA Y | 09-007 | 09-012 |  |  |  |  |  |  |  |  | 0 | APP |  | 08-016 |  | 631A | 10-001A |  |  |  |  | 2.10526315 | 97.89473684 | 100 | 100 | 07-029 | 09-011 | 11-001 | 12-015 |  |  |  |  |  |  |  |  |  |
| 16332020ba |  | H-D Complex P- II Constrctn Mngmnt Labor Procurement |  | 380d | 2010-02-03 A | 2011-08-10 A | 16332008 | 100% |  |  | PROCUREMENT<$50K 60 NO ESCALATION; PROCUREMENT>$50K 69 NO ESCALATION | 718,035.23 |  | 718035.23 | YASKY R | 1 | 1 |  |  |  |  | E | REBECCA Y | 09-007 | 09-012 |  |  |  |  | 0 | 718035.23 | 71803523 | 100 | 0 | APP |  | 08-016 |  | 631A | 10-001A |  |  |  |  | 2.10526315 | 97.89473684 | 100 | 100 | 07-029 | 09-011 | 11-001 | 12-015 |  |  |  |  |  |  |  |  |  |
| 16332025 |  | H-D Complex P- II A-E Constrctn Supprt |  | 380d | 2010-02-03 A | 2011-08-10 A | 16332008 | 100% |  |  | PROCUREMENT<$50K 60 NO ESCALATION FY11 | 163,225.89 |  | 163225.89041 | YASKY R | 1 | 1 |  |  |  |  | E | REBECCA Y | 09-007 | 09-012 |  |  |  |  | 0 | 163225.89041 | 16322589.041 | 100 | 0 | APP |  | 08-016 |  | 631B |  |  |  |  |  | 2.10526315 | 97.89473684 | 100 | 100 |  |  |  |  | 08-034 | 10-028 | 12-029F |  |  |  |  |  |  |
| 16332010A |  | H-D Complex P- II Contract Progress 2010 ETC FY10 |  | 453.29d | 2010-04-01 A | 2012-01-31 A | 9-100M FS+97d | 100% |  |  | MECH ENG [42.69 h]; MECH TECH [384.17 h] | 19,382.92 | 19,382.92 | 18846.3923 | YASKY R | 1 | 1 |  |  |  |  | C | REBECCA Y |  |  |  |  | 11-004 |  |  |  |  |  | 0 | APP |  |  |  | 631B |  |  |  |  |  |  |  |  |  |  |  | 11-001 |  |  |  |  | 10-019 |  |  |  |  |  |
| 16332010Ab |  | H-D Complex P- II Contract Progress 2010 ETC FY11 |  | 454d | 2010-04-01 A | 2012-01-31 A | 16332010A FS-132d | 100% |  |  | MECH ENG [37.31 h]; MECH TECH [335.83 h] | 16,944.35 | 16,944.35 | 16999.4126 | YASKY R | 1 | 1 |  |  |  |  | C | REBECCA Y |  |  |  |  | 11-004 |  |  |  |  |  | 0 | APP |  |  |  | 631B |  |  |  |  |  |  |  |  |  |  |  | 11-001 |  |  |  |  | 10-019 |  |  |  |  |  |
| 16332020A |  | H-D Complex P- II Constrctn Mngmnt 2010 ETC Labor FY10 |  | 339.72d | 2010-04-01 A | 2011-08-10 A | 9-100M FS+97d | 100% |  |  | MECH TECH [332.78 h]; PLANT ENG [66.56 h]; ELEC ENG [33.28 h]; MECH ENG [166.39 h] | 32,067.92 | 32,098.92 | 31443.4475 | YASKY R | 1 | 1 |  |  |  |  | E | REBECCA Y |  |  |  |  |  |  |  |  |  |  | 0 | APP |  |  |  | 631A |  |  |  |  |  | 5.29801324 | 94.70198675 | 100 | 100 |  |  | 11-001 | 12-015 |  |  |  | 10-019 |  |  |  |  |  |
| 16332020Aa |  | H-D Complex P- II Constrctn Mngmnt 2010 ETC Labor FY11 |  | 339.46d | 2010-04-01 A | 2011-08-10 A | 16332020A FS-212d | 100% |  |  | MECH ENG [233.61 h]; MECH TECH [467.22 h]; PLANT ENG [93.44 h]; ELEC ENG [46.72 h] | 45,021.67 | 45,065.3 | 45552.1393 | YASKY R | 1 | 1 |  |  |  |  | E | REBECCA Y |  |  |  |  |  |  |  |  |  |  | 0 | APP |  |  |  | 631A |  |  |  |  |  | 3.7735849 | 96.22641509 | 100 | 100 |  |  | 11-001 | 12-015 |  |  |  | 10-019 |  |  |  |  |  |
| 16332020Ab |  | H-D Complex P- II Constrctn Mngmnt 2010 ETC Procurement |  | 340d | 2010-04-01 A | 2011-08-10 A | 9-100M FS+97d | 100% |  |  | PROCUREMENT>$50K 69 NO ESCALATION | 206,000 |  | 206000 | YASKY R | 1 | 1 |  |  |  |  | E | REBECCA Y |  |  |  |  |  |  | 0 | 206000 | 20600000 | 100 | 0 | APP |  |  |  | 631A |  |  |  |  |  | 2.20385674 | 97.79614325 | 100 | 100 |  |  | 11-001 | 12-015 |  |  |  | 10-019 |  |  |  |  |  |
| 16332040 |  | H-D Complex Cryo Plant P- II Contract Progress September 2010 Progress Payment |  | 145d | 2010-04-01 A | 2010-10-25 A | 16332008 | 100% |  |  | PROCUREMENT>$50K 69 NO ESCALATION | 14,625 |  | 14625 | YASKY R | 1 | 1 |  |  |  |  | C | REBECCA Y | 09-007 | 09-012 |  | 10-059 |  |  | 0 | 14625 | 1462500 | 100 | 0 |  | 08-014 | 08-016 | 09-010 | 631B | 10-001A |  |  |  |  |  |  |  |  |  |  |  |  |  |  |  |  | 08-056 |  |  |  |  |
| 16332040A |  | H-D Complex Cryo Plant P- II Contract Progress October 2010 Progress Payment |  | 149d | 2010-04-01 A | 2010-10-29 A | 16332040 FS-168d | 100% |  |  | PROCUREMENT>$50K 69 NO ESCALATION | 20,740 |  | 20740 | YASKY R | 1 | 1 |  |  |  |  | C | REBECCA Y |  |  |  | 10-059 |  |  | 0 | 20740 | 2074000 | 100 | 0 |  |  |  |  | 631B |  |  |  | 11-020 |  |  |  |  |  |  |  |  |  |  |  |  |  |  |  |  |  |  |
| 16332040B |  | H-D Complex Cryo Plant P- II Contract Progress November 2010 Progress Payment |  | 165d | 2010-04-01 A | 2010-11-22 A | 16332040A FS-189d | 100% |  |  | PROCUREMENT>$50K 69 NO ESCALATION | 39,564 |  | 39564 | YASKY R | 1 | 1 |  |  |  |  | C | REBECCA Y |  |  |  | 10-059 |  |  | 0 | 39564 | 3956400 | 100 | 0 |  |  |  |  | 631B |  |  |  | 11-020 |  |  |  |  |  |  |  |  |  |  |  |  |  |  |  |  |  |  |
| 16332040C |  | H-D Complex Cryo Plant P- II Contract Progress December 2010 Progress Payment |  | 165d | 2010-04-01 A | 2010-11-22 A | 16332040B FS-209d | 100% |  |  | PROCUREMENT>$50K 69 NO ESCALATION | 9,095.68 |  | 9095.68 | YASKY R | 1 | 1 |  |  |  |  | C | REBECCA Y |  |  |  | 10-059 |  |  | 0 | 9095.68 | 909568 | 100 | 0 |  |  |  |  | 631B |  |  |  | 11-020 |  |  |  |  |  |  |  |  |  |  |  |  |  |  |  |  |  |  |
| 16332040D |  | H-D Complex Cryo Plant P- II Contract Progress January 2011 Progress Payment |  | 244d | 2010-04-01 A | 2011-03-25 A | 16332040C FS-226d | 100% |  |  | PROCUREMENT>$50K 69 NO ESCALATION | 90,834 |  | 90834 | YASKY R | 1 | 1 |  |  |  |  | C | REBECCA Y |  |  |  | 10-059 |  |  | 0 | 90834 | 9083400 | 100 | 0 |  |  |  |  | 631B |  |  |  | 11-020 |  |  |  |  |  |  |  |  |  |  |  |  |  |  |  |  |  |  |
| 16332040F |  | H-D Complex Cryo Plant P- II Contract Progress February 2011 Progress Payment |  | 376d | 2010-04-01 A | 2011-09-30 A | 16332040D FS-246d | 100% |  |  | PROCUREMENT>$50K 69 NO ESCALATION | 40,288 |  | 40288 | YASKY R | 1 | 1 |  |  |  |  | C | REBECCA Y |  |  |  | 10-059 |  |  | 0 | 40288 | 4028800 | 100 | 0 |  |  |  |  | 631B |  |  |  | 11-020 |  |  |  |  |  |  |  |  |  |  |  |  |  |  |  |  |  |  |
| 16332015 |  | H-D Complex P- II Cmmssng |  | 211d | 2011-03-25 A | 2012-01-31 A | 16332010, 16332012, 16332040, 16332040F FS-20d, 16332011 FS-500d, 16332010U FS-500d, 16332010Ab FS-40d | 100% |  |  | PROCUREMENT<$50K 60 | 96,376.11 |  | 96376.11 | YASKY R | 1 | 1 |  |  |  |  | C | REBECCA Y | 09-007 |  |  | 10-059 | 11-004 |  | 0 | 96376.11 | 9637611 | 100 | 0 | APP |  |  |  | 631B |  |  |  |  |  |  |  |  |  |  |  |  |  |  |  |  |  |  |  |  |  |  |
| 16332045 |  | H-D Elect Utilities Proc Telecomm Cable & Equip |  | 81d | 2011-05-02 A | 2011-08-24 A | 16332010U FS-140d, 16332010 FS-80d | 100% |  |  | SCIENTIST [160 h] | 10,948.8 | 10,948.8 | 10948.8 | YASKY R | 1 | 1 |  |  |  |  | C | REBECCA Y | 09-007 |  |  | 10-059 |  |  |  |  |  |  | 0 |  |  |  |  |  |  |  |  |  |  |  |  |  |  |  |  |  |  |  |  |  |  |  |  |  |  |  |
| 16332050 |  | H-D Elect Utilities Install Telecomm Cable & Equip |  | 163d | 2011-05-02 A | 2011-12-22 A | 16332045 FS-40d, 16332010, 16332010U FS-110d | 100% | 2011-05-02 | 2011-12-21 | PROCUREMENT>$50K 69; PROCUREMENT<$50K 60 | 102,045.28 |  | 102045.28 | YASKY R | 1 | 1 |  |  |  |  | C | REBECCA Y | 09-007 |  |  | 10-059 |  |  | 0 | 102045.28 | 10204528 | 100 | 0 |  |  |  |  | 631B |  |  |  |  |  |  |  |  |  |  |  |  |  |  |  |  |  |  |  |  |  |  |
| 16332010W |  | H-D Complex P-II Contractor Claim #2 |  | 20d | 2012-01-02 A | 2012-01-31 A | 9-120M FS+59d | 100% | 2012-01-03 | 2012-01-31 | PROCUREMENT>$50K 69 NO ESCALATION; PROCUREMENT<$50K 60 NO ESCALATION | 300,000 |  | 300000 | YASKY R | 1 | 1 |  |  | 08-017 |  | C | REBECCA Y | 09-007 |  | 09-044 |  |  |  | 0 | 300000 | 30000000 | 100 | 0 | APP | 08-014 |  | 09-010 | 631B | 10-001A |  |  |  |  |  |  |  |  |  |  |  | 12-015 |  |  |  |  |  | 11-026 | 11-047 | 12-009 |  |
| 16332030 |  | H-D Complex P- II Beneficial Occupancy |  | 16d | 2012-01-09 A | 2012-01-31 A | 16332050 FS-22d, 16332010U, 16332010, 16332015 FS-15d, 16332010V FS-15d | 100% |  |  | PLANT ENG [40 h] | 2,809.6 | 2,809.6 | 2809.6 | YASKY R | 1 | 1 |  |  | 08-017 | 08-023 | H | REBECCA Y | 09-007 |  |  | 10-059 |  | 11-044 |  |  |  |  | 0 |  |  |  |  |  |  |  |  |  |  |  |  |  |  |  |  |  |  |  |  |  |  |  |  |  |  |  |
| 16332035 |  | H-D Complex P- II Constr Comp | milestone | 0d | 2012-01-31 A | 2012-01-31 A | 16332025, 16332030, 16332020Aa, 16332020ba, 13455135, 16332020Ab, 16332020b, 16332010W FS-60d | 100% | 2012-02-28 | 2012-02-28 |  |  |  | 0 | YASKY R | 1 | 1 |  |  |  |  | M | REBECCA Y | 09-007 |  |  | 10-059 |  | 11-044 |  |  |  |  |  |  |  |  |  |  |  | 6 | D |  |  |  |  |  |  |  |  |  | 12-015 |  |  |  |  |  |  |  |  |  |
| 16332055 |  | Re-Baseline Actuals Adjustment |  | 1d | 2013-08-30 A | 2013-08-30 A |  | 100% | 2013-09-03 | 2013-09-03 | PROCUREMENT>$50K 69 NO ESCALATION | 364,195.36 |  | 364195.36 |  |  |  |  |  |  |  |  |  |  |  |  |  |  |  | 0 | 364195.36 | 36419536 | 100 |  |  |  |  |  |  |  |  |  |  |  |  |  |  |  |  |  |  |  |  |  |  |  |  |  |  |  | ADJ |

Notes:
- 16332010: Explanation: Phase 2 Totals are 16332010 Contract Progress and 16332040 Cryo Plant / Combined = $6,412,552.93 03 Sept 2009.
- 16332010B: Explanation: Phase 2 Totals are 16332010 Contract Progress and 16332040 Cryo Plant / Combined = $6,412,552.93 03 Sept 2009.
- 16332010C: Explanation: Phase 2 Totals are 16332010 Contract Progress and 16332040 Cryo Plant / Combined = $6,412,552.93 03 Sept 2009.
- 16332010D: Explanation: Phase 2 Totals are 16332010 Contract Progress and 16332040 Cryo Plant / Combined = $6,412,552.93 03 Sept 2009.
- 16332010F: Explanation: Phase 2 Totals are 16332010 Contract Progress and 16332040 Cryo Plant / Combined = $6,412,552.93 03 Sept 2009.
- 16332010G: Explanation: Phase 2 Totals are 16332010 Contract Progress and 16332040 Cryo Plant / Combined = $6,412,552.93 03 Sept 2009.
- 16332010H: Explanation: Phase 2 Totals are 16332010 Contract Progress and 16332040 Cryo Plant / Combined = $6,412,552.93 03 Sept 2009.
- 16332010J: Explanation: Phase 2 Totals are 16332010 Contract Progress and 16332040 Cryo Plant / Combined = $6,412,552.93 03 Sept 2009.
- 16332010K: Explanation: Phase 2 Totals are 16332010 Contract Progress and 16332040 Cryo Plant / Combined = $6,412,552.93 03 Sept 2009.
- 16332010N: Explanation: Phase 2 Totals are 16332010 Contract Progress and 16332040 Cryo Plant / Combined = $6,412,552.93 03 Sept 2009.
- 16332010P: Explanation: Phase 2 Totals are 16332010 Contract Progress and 16332040 Cryo Plant / Combined = $6,412,552.93 03 Sept 2009.
- 16332010Q: Explanation: Phase 2 Totals are 16332010 Contract Progress and 16332040 Cryo Plant / Combined = $6,412,552.93 03 Sept 2009.
- 16332010R: Explanation: Phase 2 Totals are 16332010 Contract Progress and 16332040 Cryo Plant / Combined = $6,412,552.93 03 Sept 2009.
- 16332010S: Explanation: Phase 2 Totals are 16332010 Contract Progress and 16332040 Cryo Plant / Combined = $6,412,552.93 03 Sept 2009.
- 16332010T: Explanation: Phase 2 Totals are 16332010 Contract Progress and 16332040 Cryo Plant / Combined = $6,412,552.93 03 Sept 2009.
- 16332010U: Explanation: Phase 2 Totals are 16332010 Contract Progress and 16332040 Cryo Plant / Combined = $6,412,552.93 03 Sept 2009.
- 16332010V: Explanation: Phase 2 Totals are 16332010 Contract Progress and 16332040 Cryo Plant / Combined = $6,412,552.93 03 Sept 2009.
- 16332011: Explanation: Progress to follow Activity 16332010 PMK 28 / February10
- 16332020: Corrective Actions: Deleted FY12 funding as a / predecessor.
- 16332020b: Corrective Actions: Deleted FY12 funding as a / predecessor.
- 16332020ba: Corrective Actions: Deleted FY12 funding as a / predecessor.
- 16332010A: Explanation: Phase 2 Totals are 16332010 Contract Progress and 16332040 Cryo Plant / Combined = $6,412,552.93 03 Sept 2009.
- 16332010Ab: Explanation: Phase 2 Totals are 16332010 Contract Progress and 16332040 Cryo Plant / Combined = $6,412,552.93 03 Sept 2009.
- 16332020A: Corrective Actions: Deleted FY12 funding as a predecessor. / Changed EVMS Code from C to E as and Administrative Change PMK / 12/6/10
- 16332020Aa: Corrective Actions: Deleted FY12 funding as a predecessor. / Changed EVMS Code from C to E as and Administrative Change PMK / 12/6/10
- 16332020Ab: Corrective Actions: Deleted FY12 funding as a predecessor. / Changed EVMS Code from C to E as and Administrative Change PMK / 12/6/10
- 16332040: Explanation: Phase 2 Totals are 16332010 Contract / Progress and 16332040 Cryo Plant Combined = $6,412,552.93 03 / Sept 2009.
- 16332040A: Explanation: Phase 2 Totals are 16332010 Contract Progress and 16332040 Cryo Plant / Combined = $6,412,552.93 03 Sept 2009.
- 16332040B: Explanation: Phase 2 Totals are 16332010 Contract Progress and 16332040 Cryo Plant / Combined = $6,412,552.93 03 Sept 2009.
- 16332040C: Explanation: Phase 2 Totals are 16332010 Contract Progress and 16332040 Cryo Plant / Combined = $6,412,552.93 03 Sept 2009.
- 16332040D: Explanation: Phase 2 Totals are 16332010 Contract Progress and 16332040 Cryo Plant / Combined = $6,412,552.93 03 Sept 2009.
- 16332040F: Explanation: Phase 2 Totals are 16332010 Contract Progress and 16332040 Cryo Plant / Combined = $6,412,552.93 03 Sept 2009.

| ID | WBS | Activity | Type | Duration | Start | Finish | Predecessors | Complete | Remaining | Planned start | Planned finish | Total float | Free float | Calendar | Resources | Cost | Actual cost | MONTHLY EV COST | RESP - Responsibility | STRT%COMP for CM EVM | FNSH%COMP for CM EVM | CR 08-017 | EVMS Reporting Codes | CAM RESPONSIBLE | CR 09-007 | CR 09-044 | CR 11-026 | CR 11-047 | CR 12-018 | Remaining Material Cost Based on % Compl | Claimed Material Cost Based on % Complet | Initial Claimed Material Calc | Claimed Material Divider | Calculated Remaining Total Cost | Advance Purchase Plan > 500K | CR 08-014 | CR 09-010 | 12 GEV MAJOR PROCUREMENT CATAGORY | CR 10-001 | Milestone Level | HALL D Related Milestones | CR 08-016 | CR 09-012 | CR 07-029 | CR 08-023 | CR 09-011 | CR 10-019 | CR 10-030 | CR 12-015 | CR 08-034 | LOE % Pre Calc | LOE % | LOE Divider | LOE Multiplier | CR 12-009 | ReBaseline Actuals Adjustment | CR 08-058 | CR 10-037 | CR 10-050 | CR 11-007 | CR 12-038 | Original Activity ID Rebaseline | PRIOR MONTH EV COST | BOE Labor | BOE Expenses | CR 13-015 | Post Rebaseline | Obligated Prior to Rebaseline | CR 14-001 |
| --- | --- | --- | --- | --- | --- | --- | --- | --- | --- | --- | --- | --- | --- | --- | --- | --- | --- | --- | --- | --- | --- | --- | --- | --- | --- | --- | --- | --- | --- | --- | --- | --- | --- | --- | --- | --- | --- | --- | --- | --- | --- | --- | --- | --- | --- | --- | --- | --- | --- | --- | --- | --- | --- | --- | --- | --- | --- | --- | --- | --- | --- | --- | --- | --- | --- | --- | --- | --- | --- |
|  | 3 | **1.6.3.3.3 PHASE 3** |  |  | 2009-08-06 | 2013-08-30 |  |  |  |  |  |  |  |  |  |  |  |  |  |  |  |  |  |  |  |  |  |  |  |  |  |  |  |  |  |  |  |  |  |  |  |  |  |  |  |  |  |  |  |  |  |  |  |  |  |  |  |  |  |  |  |  |  |  |  |  |  |  |  |
| 16333005 |  | H-D Complex P- III Award Contract |  | 1d | 2009-08-06 A | 2009-08-06 A | 9-090M FS+209d | 100% |  |  |  |  |  |  |  |  |  | 0 | YASKY R | 1 | 1 | 08-017 | Z | REBECCA Y | 09-007 | 09-044 | 11-026 | 11-047 | 12-018F |  |  |  |  |  |  |  |  |  |  |  |  |  |  |  |  |  |  |  |  |  |  |  |  |  |  |  |  |  |  |  |  |  |  |  |  |  |  |  |  |
| 16333010 |  | H-D Complex P- III Contract Progress June 2011 |  | 487d | 2009-08-06 A | 2011-07-25 A | 16333005 FS-1d | 100% |  |  |  |  |  |  | PROCUREMENT<$50K 60 NO ESCALATION; PROCUREMENT>$50K 69 NO ESCALATION | 123,072.9 |  | 123073 | YASKY R | 1 | 1 | 08-017 | C | REBECCA Y | 09-007 | 09-044 | 11-026 | 11-047 | 12-018F | 0 | 123072.9 | 12307290 | 100 | 0 | APP | 08-014 | 09-010 | 631B | 10-001A |  |  |  |  |  |  |  |  |  |  |  |  |  |  |  |  |  |  |  |  |  |  |  |  |  |  |  |  |  |  |
| 16333010A |  | H-D Complex P- III Contract Progress July 2011 |  | 511d | 2009-08-06 A | 2011-08-26 A | 16333010 FS-471d | 100% |  |  |  |  |  |  | PROCUREMENT>$50K 69 NO ESCALATION | 115,281.56 |  | 115281.56 | YASKY R | 1 | 1 | 08-017 | C | REBECCA Y | 09-007 | 09-044 | 11-026 | 11-047 | 12-018F | 0 | 115281.56 | 11528156 | 100 | 0 | APP | 08-014 | 09-010 | 631B | 10-001A |  |  |  |  |  |  |  |  |  |  |  |  |  |  |  |  |  |  |  |  |  |  |  |  |  |  |  |  |  |  |
| 16333010B |  | H-D Complex P- III Contract Progress August 2011 |  | 524d | 2009-08-06 A | 2011-09-15 A | 16333010A FS-491d | 100% |  |  |  |  |  |  | PROCUREMENT>$50K 69 NO ESCALATION | 115,735 |  | 115735 | YASKY R | 1 | 1 | 08-017 | C | REBECCA Y | 09-007 | 09-044 | 11-026 | 11-047 | 12-018F | 0 | 115735 | 11573500 | 100 | 0 | APP | 08-014 | 09-010 | 631B | 10-001A |  |  |  |  |  |  |  |  |  |  |  |  |  |  |  |  |  |  |  |  |  |  |  |  |  |  |  |  |  |  |
| 16333010C |  | H-D Complex P- III Contract Progress September 2011 |  | 540d | 2009-08-06 A | 2011-10-07 A | 16333010B FS-514d | 100% |  |  |  |  |  |  | PROCUREMENT>$50K 69 NO ESCALATION | 160,000 |  | 160000 | YASKY R | 1 | 1 | 08-017 | C | REBECCA Y | 09-007 | 09-044 | 11-026 | 11-047 | 12-018F | 0 | 160000 | 16000000 | 100 | 0 | APP | 08-014 | 09-010 | 631B | 10-001A |  |  |  |  |  |  |  |  |  |  |  |  |  |  |  |  |  |  |  |  |  |  |  |  |  |  |  |  |  |  |
| 16333010D |  | H-D Complex P- III Contract Progress October 2011 |  | 558d | 2009-08-06 A | 2011-11-02 A | 16333010C FS-535d | 100% |  |  |  |  |  |  | PROCUREMENT>$50K 69 NO ESCALATION | 155,301.66 |  | 155301.66 | YASKY R | 1 | 1 | 08-017 | C | REBECCA Y | 09-007 | 09-044 | 11-026 | 11-047 | 12-018F | 0 | 155301.66 | 15530166 | 100 | 0 | APP | 08-014 | 09-010 | 631B | 10-001A |  |  |  |  |  |  |  |  |  |  |  |  |  |  |  |  |  |  |  |  |  |  |  |  |  |  |  |  |  |  |
| 16333000M |  | H-D Complex P- III Begin Constr | milestone | 0d | 2010-12-20 A | 2010-12-20 A | 9-110M FS+60d | 100% |  | 2011-01-05 | 2011-01-05 |  |  |  |  |  |  | 0 | YASKY R | 1 | 1 |  | M | REBECCA Y | 09-007 |  | 11-026 |  | 12-018F |  |  |  |  |  |  |  |  |  |  | 6 | D |  |  |  |  |  |  |  |  |  |  |  |  |  |  |  |  |  |  |  |  |  |  |  |  |  |  |  |  |
| 16333015 |  | H-D Complex P- III Cmmssng |  | 172d | 2011-03-01 A | 2011-10-31 A | 16333012 FS-150d, 16333010D FS-150d, 16333011 FS-150d | 100% |  |  |  |  |  |  | PROCUREMENT<$50K 60 NO ESCALATION FY12 | 5,850.59 |  | 5850.59 | YASKY R | 1 | 1 |  | C | REBECCA Y | 09-007 |  | 11-026 | 11-047 | 12-018F | 0 | 5850.59 | 585059 | 100 | 0 | APP |  |  | 631B |  |  |  | 08-016 | 09-012 |  |  |  |  |  |  |  |  |  |  |  |  |  |  |  |  |  |  |  |  |  |  |  |  |  |  |
| 16333020 |  | H-D Complex P- III Constrctn Mngmnt |  | 174d | 2011-03-01 A | 2011-11-02 A | 4A-01M FS-40d, 16333008 | 100% |  |  |  |  |  |  | ELEC ENG [40 h]; MECH ENG [200 h]; MECH DES [40 h]; OFFICE [40 h]; MECH TECH [1080 h]; PLANT ENG [200 h]; PROCUREMENT<$50K 60 NO ESCALATION; PROCUREMENT>$50K 69 NO ESCALATION | 512,703.06 | 79,763.18 | 512368.68 | YASKY R | 1 | 1 | 08-017 | C | REBECCA Y | 09-007 |  |  |  |  | 0 | 432939.88 | 43293988 | 100 | 0 | APP |  |  | 631A | 10-001A |  |  |  | 09-012 | 07-029 | 08-023 | 09-011 | 10-019 | 10-030 | 12-015 |  |  |  |  |  |  |  |  |  |  |  |  |  |  |  |  |  |  |  |  |
| 16333025 |  | H-D Complex P- III A-E Constrctn Supprt |  | 174d | 2011-03-01 A | 2011-11-02 A | 4A-01M FS-40d, 16333008 | 100% |  |  |  |  |  |  | PROCUREMENT<$50K 60 | 14,520.45 |  | 14520.45 | YASKY R | 1 | 1 | 08-017 | C | REBECCA Y | 09-007 |  |  |  |  | 0 | 14520.45 | 1452045 | 100 | 0 | APP |  |  | 631B |  |  |  |  | 09-012 |  | 08-023 |  |  | 10-030 | 12-015 | 08-034 |  |  |  |  |  |  |  |  |  |  |  |  |  |  |  |  |  |  |  |
| 16333011 |  | H-D Complex P- III Contract Modifications |  | 130d | 2011-03-18 A | 2011-09-20 A | 16333008, 4A-01M FS-40d | 100% |  |  |  |  |  |  | PROCUREMENT>$50K 69 NO ESCALATION | 31,432.19 |  | 31432.19 | YASKY R | 1 | 1 | 08-017 | E | REBECCA Y | 09-007 |  | 11-026 |  | 12-018F | 0 | 31432.19 | 3143219 | 100 | 0 | APP | 08-014 | 09-010 | 631B | 10-001A |  |  |  |  |  |  |  |  | 10-030 |  |  | 10 | 90 | 100 | 100 |  |  |  |  |  |  |  |  |  |  |  |  |  |  |  |
| 16333012 |  | H-D Complex P- III ARRA Funds |  | 130d | 2011-03-18 A | 2011-09-20 A | 4A-01M FS-40d, 16333008 | 100% |  |  |  |  |  |  | PROCUREMENT>$50K 69 NO ESCALATION | 27,562.42 |  | 27562.42 | YASKY R | 1 | 1 |  | E | REBECCA Y |  | 09-044 | 11-026 |  | 12-018F | 0 | 27562.42 | 2756242 | 100 | 0 | APP |  |  | 631B | 10-001A |  |  |  |  |  |  |  |  | 10-030 |  |  | 10 | 90 | 100 | 100 |  |  |  |  |  |  |  |  |  |  |  |  |  |  |  |
| 16333008 |  | H-D Complex P- III Notice to Proceed |  | 2d | 2011-05-13 A | 2011-05-16 A | 16333000M | 100% |  |  |  |  |  |  |  |  |  | 0 | YASKY R | 1 | 1 |  | Z | REBECCA Y |  | 09-044 | 11-026 | 11-047 | 12-018F |  |  |  |  |  |  |  |  |  |  |  |  |  |  |  |  |  |  |  |  |  |  |  |  |  |  |  |  |  |  |  |  |  |  |  |  |  |  |  |  |
| 16333030 |  | H-D Complex P- III Beneficial Occupancy |  | 1d | 2011-11-02 A | 2011-11-02 A | 16333010D FS-556d, 16333011, 16333015 FS-10d | 100% |  |  |  |  |  |  | PLANT ENG [40 h] | 2,809.6 | 2,809.6 | 2809.6 | YASKY R | 1 | 1 |  | H | REBECCA Y | 09-007 |  | 11-026 | 11-047 | 12-018F |  |  |  |  | 0 |  |  |  |  |  |  |  |  |  |  |  |  |  |  |  |  |  |  |  |  |  |  |  |  |  |  |  |  |  |  |  |  |  |  |  |
| 16333035 |  | H-D Complex P- III Constr Comp | milestone | 0d | 2011-11-02 A | 2011-11-02 A | 16333010F FS-60d, 16333030, 16333020, 16333025 | 100% |  | 2012-01-05 | 2012-01-05 |  |  |  |  |  |  | 0 | YASKY R | 1 | 1 |  | M | REBECCA Y | 09-007 |  |  | 11-047 |  |  |  |  |  |  |  |  |  |  |  | 6 | D |  |  |  |  |  |  |  | 12-015 |  |  |  |  |  |  |  |  |  |  |  |  |  |  |  |  |  |  |  |  |
| 16333010F |  | H-D Complex P-III Contractor Claim #2 |  | 5d | 2011-12-01 A | 2011-12-07 A | 9-120M FS+41d | 100% |  |  |  |  |  |  | PROCUREMENT>$50K 69 NO ESCALATION; PROCUREMENT<$50K 60 NO ESCALATION | 355,000 |  | 355000 | YASKY R | 1 | 1 | 08-017 | C | REBECCA Y | 09-007 | 09-044 | 11-026 | 11-047 |  | 0 | 355000 | 35500000 | 100 | 0 | APP | 08-014 | 09-010 | 631B | 10-001A |  |  |  |  |  |  |  |  |  | 12-015 |  |  |  |  |  | 12-009 |  |  |  |  |  |  |  |  |  |  |  |  |  |  |
| 16333040 |  | Re-Baseline Actuals Adjustment |  | 1d | 2013-08-30 A | 2013-08-30 A |  | 100% |  | 2013-09-03 | 2013-09-03 |  |  |  | PROCUREMENT>$50K 69 NO ESCALATION | -30,133.8 |  |  |  |  |  |  |  |  |  |  |  |  |  |  |  |  | 100 |  |  |  |  |  |  |  |  |  |  |  |  |  |  |  |  |  |  |  |  |  |  | ADJ |  |  |  |  |  |  |  |  |  |  |  |  |  |
|  | 7 | **1.7 PROJECT MANAGEMENT** |  |  | 2008-10-01 | 2014-09-30 |  |  |  |  |  |  |  |  |  |  |  |  |  |  |  |  |  |  |  |  |  |  |  |  |  |  |  |  |  |  |  |  |  |  |  |  |  |  |  |  |  |  |  |  |  |  |  |  |  |  |  |  |  |  |  |  |  |  |  |  |  |  |  |
|  | 1 | **1.7.1 PROJECT OFFICE** |  |  | 2009-01-02 | 2014-09-30 |  |  |  |  |  |  |  |  |  |  |  |  |  |  |  |  |  |  |  |  |  |  |  |  |  |  |  |  |  |  |  |  |  |  |  |  |  |  |  |  |  |  |  |  |  |  |  |  |  |  |  |  |  |  |  |  |  |  |  |  |  |  |  |
| 171909LOE |  | FY09 Constrctn Proj Office Proj Mngmnt |  | 189d | 2009-01-02 A | 2009-09-30 A | 171909LOEX | 100% |  |  |  |  |  |  | DIRECTORATE [548.71 h]; SUPPLIES & MATERIALS; SCIENTIST [670.65 h]; SR STAFF [5365.16 h]; ADMIN [1341.29 h]; ELEC ENG [2682.58 h]; OFFICE [1341.29 h] | 1,061,187.37 | 969,066.56 | 1061187.3824 | PARKINSON J | 1 | 1 |  | E | CLAUS R |  |  |  |  |  |  |  |  |  | 0 |  |  |  |  |  |  |  |  |  |  |  |  |  |  |  |  |  |  | 100 | 100 |  |  | 08-058 |  |  |  |  |  |  |  |  |  |  |  |  |
| 171910LOE |  | FY10 Constrctn Proj Office Proj Mngmnt |  | 248d | 2009-10-01 A | 2010-09-30 A | 171909LOE | 100% |  |  |  |  |  |  | SR STAFF [7040 h]; SCIENTIST [880 h]; OFFICE [1760 h]; ELEC ENG [3520 h]; SUPPLIES & MATERIALS; DIRECTORATE [720 h]; ADMIN [1760 h] | 1,406,243.55 | 1,312,121.6 | 1406243.551732 | PARKINSON J | 1 | 1 |  | E | CLAUS R |  |  |  |  |  |  |  |  |  | 0 |  |  |  |  |  |  |  |  |  |  |  |  |  |  |  |  |  |  | 100 | 100 |  |  |  |  |  |  |  |  |  |  |  |  |  |  |  |
| 171910ALOE |  | FY10 Constrctn Proj Office Proj Mngmnt (Accelerator Work Coordinator) |  | 151d | 2010-03-01 A | 2010-09-30 A | 9-100M FS+97d | 100% |  |  |  |  |  |  | MECH ENG [1320 h] | 86,922 | 86,922 | 86922 | PARKINSON J | 1 | 1 |  | E | CLAUS R |  |  |  |  |  |  |  |  |  | 0 |  |  |  |  |  |  |  |  |  |  |  |  |  |  |  |  |  |  | 100 | 100 |  |  |  | 10-037 |  |  |  |  |  |  |  |  |  |  |  |
| 171910BLOE |  | FY10 Constrctn Proj Office Proj Mngmnt (CR 10-050) |  | 128d | 2010-04-01 A | 2010-09-30 A | 9-100M FS+120d | 100% |  |  |  |  |  |  | SUPPLIES & MATERIALS | 120,000 |  | 120000 | PARKINSON J | 1 | 1 |  | E | CLAUS R |  |  |  |  |  |  |  |  |  | 0 |  |  |  |  |  |  |  |  |  |  |  |  |  |  |  |  |  |  | 100 | 100 |  |  |  |  | 10-050 |  |  |  |  |  |  |  |  |  |  |
| 171911LOE |  | FY11 Constrctn Proj Office Proj Mngmnt |  | 248d | 2010-10-01 A | 2011-09-30 A | 171910BLOE, 171910LOE, 171910ALOE | 100% |  |  |  |  |  |  | DIRECTORATE [2216 h]; SUPPLIES & MATERIALS; OFFICE [1760 h]; SCIENTIST [880 h]; MECH ENG [1760 h]; ADMIN [1760 h]; ELEC ENG [3520 h]; SR STAFF [5544 h] | 1,818,372.05 | 1,586,669.28 | 1818372.05 | PARKINSON J | 1 | 1 |  | E | CLAUS R |  |  |  |  |  |  |  |  |  | 0 |  |  |  |  |  |  |  |  |  |  |  |  |  |  |  |  | 8.46774193 | 91.53225806 | 100 | 100 |  |  |  | 10-037 | 10-050 | 11-007 |  |  |  |  |  |  |  |  |  |
| 171911LOEA |  | FY11 Constrctn Proj Office Proj Mngmnt CR11-007 Reductions |  | 227d | 2010-11-01 A | 2011-09-30 A | 171910LOE FS+21d | 100% |  |  |  |  |  |  | ELEC ENG [-1760 h]; SCIENTIST [-704 h]; SUPPLIES & MATERIALS | -360,226.29 | -168,523.52 |  | PARKINSON J | 1 | 1 |  | E | CLAUS R |  |  |  |  |  |  |  |  |  |  |  |  |  |  |  |  |  |  |  |  |  |  |  |  |  |  | 9.25110132 | 90.74889867 | 100 | 100 |  |  |  | 10-037 | 10-050 | 11-007 |  |  |  |  |  |  |  |  |  |
| 171911LOEB |  | FY11 Constrctn Proj Office Proj Mngmnt CR11-007 |  | 227d | 2010-11-01 A | 2011-09-30 A | 171910LOE FS+21d | 100% |  |  |  |  |  |  | SR STAFF [352 h]; MECH ENG [5016 h]; DIRECTORATE [688 h]; OFFICE [880 h] | 531,076.24 | 531,076.24 | 531076.24 | PARKINSON J | 1 | 1 |  | E | CLAUS R |  |  |  |  |  |  |  |  |  | 0 |  |  |  |  |  |  |  |  |  |  |  |  |  |  |  |  | 9.25110132 | 90.74889867 | 100 | 100 |  |  |  | 10-037 | 10-050 | 11-007 |  |  |  |  |  |  |  |  |  |
| 171912LOE |  | FY12 Constrctn Proj Office Proj Mngmnt Part A |  | 120.82d | 2011-10-03 A | 2012-04-02 A | 171911LOE, 171911LOEA, 171911LOEB | 100% |  |  |  |  |  |  | OFFICE [1710.12 h]; ELEC ENG [855.06 h]; SUPPLIES & MATERIALS; MECH ENG [3291.98 h]; DIRECTORATE [1410.85 h]; ADMIN [855.06 h]; SR STAFF [2864.45 h] | 1,003,411.03 | 983,357.91 | 1003411.0331 | PARKINSON J | 1 | 1 |  | E | CLAUS R |  |  |  |  |  |  |  |  |  | 0 |  |  |  |  |  |  |  |  |  |  |  |  |  |  |  |  | 51.41700404 | 48.58299595 | 100 | 100 |  |  |  | 10-037 | 10-050 | 11-007 | 12-038 |  |  |  |  |  |  |  |  |
| 171912LOEA |  | FY12 Constrctn Proj Office Proj Mngmnt Part B |  | 127d | 2012-04-02 A | 2012-09-28 A | 171912LOE | 100% |  |  |  |  |  |  | SR STAFF [2200 h]; ADMIN [880 h]; OFFICE [1760 h]; ELEC ENG [880 h]; DIRECTORATE [1452 h]; SUPPLIES & MATERIALS; MECH ENG [1760 h] | 833,360.68 | 813,360.68 | 833360.68 | PARKINSON J | 1 | 1 |  | E | CLAUS R |  |  |  |  |  |  |  |  |  | 0 |  |  |  |  |  |  |  |  |  |  |  |  |  |  |  |  | 14.96062992 | 85.03937007 | 100 | 100 |  |  |  | 10-037 | 10-050 | 11-007 | 12-038 |  |  |  |  |  |  |  |  |
| 171913LOE |  | FY13 Constrctn Proj Office Proj Mngmnt Part A |  | 120d | 2012-10-01 A | 2013-03-29 A | 171912LOEA, 13451912LOE, 171912LOE | 100% |  |  |  |  |  |  | ADMIN [880 h]; ELEC ENG [880 h]; SUPPLIES & MATERIALS; SR STAFF [2200 h]; DIRECTORATE [1452 h]; MECH ENG [1760 h]; OFFICE [1760 h] | 859,930.96 | 839,292.96 | 859930.96 | PARKINSON J | 1 | 1 |  | E | CLAUS R |  |  |  |  |  |  |  |  |  | 0 |  |  |  |  |  |  |  |  |  |  |  |  |  |  |  |  | 17.5 | 82.5 | 100 | 100 |  |  |  | 10-037 | 10-050 | 11-007 | 12-038 |  |  |  |  |  |  |  |  |
| 171913LOEA |  | FY13 Constrctn Proj Office Proj Mngmnt Part B |  | 128d | 2013-04-01 A | 2013-08-30 A | 171913LOE | 100% |  | 2013-05-01 | 2013-10-30 |  |  |  | OFFICE [1485 h]; SUPPLIES & MATERIALS; SR STAFF [1856.25 h]; DIRECTORATE [1225.13 h]; ADMIN [742.5 h]; MECH ENG [1485 h]; ELEC ENG [742.5 h] | 729,450.41 | 709,144.37 | 725567.214946 | PARKINSON J | 1 | 1 |  | E | CLAUS R |  |  |  |  |  |  |  |  |  | 282143.347976 |  |  |  |  |  |  |  |  |  |  |  |  |  |  |  |  | 15.625 | 84.375 | 100 | 100 |  |  |  | 10-037 | 10-050 | 11-007 | 12-038 |  |  |  |  |  |  |  |  |
| 171950 |  | Re-Baseline Actuals Adjustment |  | 1d | 2013-08-30 A | 2013-08-30 A |  | 100% |  | 2013-09-03 | 2013-09-03 |  |  |  | PROCUREMENT>$50K 69 NO ESCALATION | -836,039.64 |  |  |  |  |  |  |  |  |  |  |  |  |  |  |  |  | 100 |  |  |  |  |  |  |  |  |  |  |  |  |  |  |  |  |  |  |  |  |  |  | ADJ |  |  |  |  |  |  |  |  |  |  |  |  |  |
| 271913LOEB |  | FY13 Constrctn Proj Office Proj Mngmnt Part B |  | 20d | 2013-09-03 A | 2013-09-30 A | 9-130M FS+228d | 100% |  | 2013-10-01 | 2013-10-28 |  |  | 8/5 M-F w/JLAB Holidays ReBaseline | SCIENTIST [14.07 h]; OFFICE [140.79 h]; SUPPLIES & MATERIALS; SR STAFF [179.51 h]; DIRECTORATE [123.18 h]; ADMIN [70.4 h]; ELEC ENG [35.2 h]; MECH ENG [140.79 h]; PROCUREMENT<$50K 60 | 71,175.52 | 67,397.5 | 0 | RODE C | 1 | 1 |  | E | CLAUS R |  |  |  |  |  | 0 | 1279.95 | 127995 | 100 |  |  |  |  |  |  |  |  |  |  |  |  |  |  |  |  |  |  |  | 100 | 100 |  |  |  | 10-037 | 10-050 | 11-007 | 12-038 | 271913LOEB | 69025.197959 | PE | PE | 13-015 | PR | OB |  |
| 271914LOE |  | FY14 Constrctn Proj Office Proj Mngmnt |  | 247d | 2013-10-01 A | 2014-09-30 | 271913LOEB | 9% | 224d | 2013-11-01 | 2014-10-31 | 311d | 0d | 8/5 M-F w/JLAB Holidays ReBaseline | SR STAFF [2244 h]; DIRECTORATE [1737.4 h]; ADMIN [880 h]; ELEC ENG [440 h]; MECH ENG [1760 h]; SCIENTIST [176 h]; OFFICE [1760 h]; SUPPLIES & MATERIALS | 930,872.11 | 84,697.77 | 86664.1932548 | RODE C | 1 | 1 |  | E | CLAUS R |  |  |  |  |  |  |  |  |  |  |  |  |  |  |  |  |  |  |  |  |  |  |  |  |  |  | 90.6882591 | 9.31174089 | 100 | 100 |  |  |  | 10-037 | 10-050 | 11-007 | 12-038 | 271914LOE |  | PE | PE | 13-015 | PR |  | 14-001 |

| ID | WBS | Activity | Duration | Start | Finish | Predecessors | Complete | Remaining | Planned start | Planned finish | Total float | Free float | Calendar | Resources | Cost | Actual cost | LOE Divider | LOE Multiplier | MONTHLY EV COST | RESP - Responsibility | STRT%COMP for CM EVM | FNSH%COMP for CM EVM | CR 07-024 | EVMS Reporting Codes | CAM RESPONSIBLE | CR 09-012 | LOE % | LOE % Pre Calc | Original Activity ID Rebaseline | CR 09-028 | CR 09-028 Repair | CR 11-026 | CR 12-025 | Post Rebaseline | CR 12-029 | CR 12-050 | 12 GeV 1st level Critical Path | CR 11-006 | CR 12-021 | CR 13-007 | CR 12-012 | CR 12-036 | CR 12-054 | CR 13-006 | CR 12-024 | CR 13-002 | CR 13-010 | GROP Group | CR 12-035 | ReBaseline Actuals Adjustment | CR 13-015 | Activities with Steps | CR 12-040 | BOE Labor | CR 14-001 | HALL D Related Milestones | CR 09-014 | CR 11-046 | CR 11-035 |
| --- | --- | --- | --- | --- | --- | --- | --- | --- | --- | --- | --- | --- | --- | --- | --- | --- | --- | --- | --- | --- | --- | --- | --- | --- | --- | --- | --- | --- | --- | --- | --- | --- | --- | --- | --- | --- | --- | --- | --- | --- | --- | --- | --- | --- | --- | --- | --- | --- | --- | --- | --- | --- | --- | --- | --- | --- | --- | --- | --- |
|  | 2 | **1.7.2 OFFICE OF PROJECT MANAGEMENT** |  | 2008-10-01 | 2013-08-30 |  |  |  |  |  |  |  |  |  |  |  |  |  |  |  |  |  |  |  |  |  |  |  |  |  |  |  |  |  |  |  |  |  |  |  |  |  |  |  |  |  |  |  |  |  |  |  |  |  |  |  |  |  |  |
| 172909LOE |  | FY09 OPM Proj Mngmnt | 248d | 2008-10-01 A | 2009-09-30 A | 1251908LOEB | 100% |  |  |  |  |  |  |  |  |  | 100 | 100 | 0 | PARKINSON J | 1 | 1 | 07-024 | Z | CLAUS R | 09-012 |  |  |  |  |  |  |  |  |  |  |  |  |  |  |  |  |  |  |  |  |  |  |  |  |  |  |  |  |  |  |  |  |  |
| 172910LOE |  | FY10 OPM Proj Mngmnt | 248d | 2009-10-01 A | 2010-09-30 A | 172909LOE | 100% |  |  |  |  |  |  |  |  |  | 100 | 100 | 0 | PARKINSON J | 1 | 1 | 07-024 | Z | CLAUS R | 09-012 |  |  |  |  |  |  |  |  |  |  |  |  |  |  |  |  |  |  |  |  |  |  |  |  |  |  |  |  |  |  |  |  |  |
| 172911LOE |  | FY11 OPM Proj Mngmnt | 248d | 2010-10-01 A | 2011-09-30 A | 172910LOE | 100% |  |  |  |  |  |  |  |  |  | 100 | 100 | 0 | PARKINSON J | 1 | 1 | 07-024 | Z | CLAUS R | 09-012 | 65.32 |  |  |  |  |  |  |  |  |  |  |  |  |  |  |  |  |  |  |  |  |  |  |  |  |  |  |  |  |  |  |  |  |
| 172912LOE |  | FY12 OPM Proj Mngmnt | 247d | 2011-10-03 A | 2012-09-28 A | 1355911LOE, 1354911LOE, 13461050LOE, 13614911LOE, 1356911LOE, 1351911LOE, 172911LOE, 13462015LOE | 100% |  |  |  |  |  |  |  |  |  | 100 | 100 | 0 | PARKINSON J | 1 | 1 | 07-024 | E | CLAUS R | 09-012 | 92.3076923 | 7.69230769 |  |  |  |  |  |  |  |  |  |  |  |  |  |  |  |  |  |  |  |  |  |  |  |  |  |  |  |  |  |  |  |
| 172913LOE |  | FY13 OPM Proj Mngmnt | 248d | 2012-10-01 A | 2013-08-30 A | 1366912LOE, 172912LOE, 13463045LOE, 13421912LOE, 1362912LOE, 13411912LOE | 100% |  | 2012-10-01 | 2013-09-30 |  |  |  |  |  |  | 100 | 100 | 0 | PARKINSON J | 1 | 1 | 07-024 | E | CLAUS R | 09-012 | 91.93548387 | 8.06451612 |  |  |  |  |  |  |  |  |  |  |  |  |  |  |  |  |  |  |  |  |  |  |  |  |  |  |  |  |  |  |  |
|  | 8 | **1.8 CONSTRUCTION PRE-OPS** |  | 2012-10-01 | 2017-12-19 |  |  |  |  |  |  |  |  |  |  |  |  |  |  |  |  |  |  |  |  |  |  |  |  |  |  |  |  |  |  |  |  |  |  |  |  |  |  |  |  |  |  |  |  |  |  |  |  |  |  |  |  |  |  |
| 28005 |  | Hall A Schedule Contingency Activity | 245d | 2014-03-13 | 2015-03-10 | 2-09M |  |  |  |  | 638d |  | 8/5 M-F w/JLAB Holidays ReBaseline |  |  |  |  |  | 0 | RODE C | 1 | 1 |  | Z | CLAUS R | 09-012 |  |  | 28005 | 09-028 | 09-028 | 11-026 | 12-025 | PR |  |  |  |  |  |  |  |  |  |  |  |  |  |  |  |  |  |  |  |  |  |  |  |  |  |
| 28000 |  | Accelerator Schedule Contingency Activity | 125d | 2014-06-26 | 2014-12-23 | 2-25M, 2-03M, 23221023L FS-200d |  |  |  |  | 0d |  | 8/5 M-F w/JLAB Holidays ReBaseline |  |  |  |  |  | 0 | HARWOOD L | 1 | 1 |  | Z | LEIGH H |  |  |  | 28000 |  |  | 11-026 | 12-025 | PR | 12-029 | 12-050 |  |  |  |  |  |  |  |  |  |  |  |  |  |  |  |  |  |  |  |  |  |  |  |
| 28010 |  | Hall D Schedule Contingency Activity | 245d | 2015-04-02 | 2016-03-29 | 3P-25M, 2-13M, 2531033, 2553010a |  |  |  |  | 377d |  | 8/5 M-F w/JLAB Holidays ReBaseline |  |  |  |  |  | 0 | RODE C | 1 | 1 |  | Z | CLAUS R |  |  |  | 28010 | 09-028 | 09-028 | 11-026 | 12-025 | PR |  |  | 1 | 11-006 | 12-021 | 13-007 |  |  |  |  |  |  |  |  |  |  |  |  |  |  |  |  |  |  |  |
| 28025 |  | Civil Schedule Contingency Activity | 245d | 2015-10-05 | 2016-09-28 | 2-38M |  |  |  |  | 249d |  | 8/5 M-F w/JLAB Holidays ReBaseline |  |  |  |  |  | 0 | RODE C | 1 | 1 |  | Z | CLAUS R |  |  |  | 28025 | 09-028 | 09-028 | 11-026 | 12-025 | PR |  |  |  |  |  |  | 12-012 | 12-036 | 12-054 | 13-006 |  |  |  |  |  |  |  |  |  |  |  |  |  |  |  |
| 28020 |  | Hall C Schedule Contingency Activity | 370d | 2016-02-09 | 2017-07-31 | 243161020, 2-33M, 3P-22M |  |  |  |  | 43d |  | 8/5 M-F w/JLAB Holidays ReBaseline |  |  |  |  |  | 0 | RODE C | 1 | 1 |  | Z | CLAUS R |  |  |  | 28020 | 09-028 | 09-028 | 11-026 | 12-025 | PR |  |  |  |  |  |  | 12-012 | 12-036 | 12-054 | 13-006 |  |  |  |  |  |  |  |  |  |  |  |  |  |  |  |
| 28015 |  | Hall B Schedule Contingency Activity | 370d | 2016-06-27 | 2017-12-19 | 2-37M, 3P-21M |  |  |  |  | -55d | 0d | 8/5 M-F w/JLAB Holidays ReBaseline |  |  |  |  |  | 0 | RODE C | 1 | 1 |  | Z | CLAUS R |  |  |  | 28015 | 09-028 | 09-028 | 11-026 | 12-025 | PR |  |  |  |  |  |  |  |  |  |  | 12-024 | 13-002 | 13-010 |  |  |  |  |  |  |  |  |  |  |  |  |
|  | 1 | **1.8.1 CONSTRUCTION ACCELERATOR PRE-OPS** |  | 2012-12-17 | 2016-06-24 |  |  |  |  |  |  |  |  |  |  |  |  |  |  |  |  |  |  |  |  |  |  |  |  |  |  |  |  |  |  |  |  |  |  |  |  |  |  |  |  |  |  |  |  |  |  |  |  |  |  |  |  |  |  |
|  | 1 | **1.8.1.1 CONSTRUCTION ACCELERATOR PRE-OPS BEAM COMMISIONING** |  | 2013-08-30 | 2016-06-24 |  |  |  |  |  |  |  |  |  |  |  |  |  |  |  |  |  |  |  |  |  |  |  |  |  |  |  |  |  |  |  |  |  |  |  |  |  |  |  |  |  |  |  |  |  |  |  |  |  |  |  |  |  |  |
| 1811019 |  | H-A ARR Process | 20d | 2013-08-30 A | 2013-08-30 A | 3A-43M | 100% |  | 2013-11-14 | 2013-12-13 |  |  |  |  |  |  |  |  | 0 | HARWOOD L | 1 | 1 |  | Z | LEIGH H |  |  |  |  |  |  | 11-026 |  |  |  |  |  |  |  |  |  |  |  |  |  |  |  | ACCL | 12-035 |  |  |  |  |  |  |  |  |  |  |
| 1811070 |  | Re-Baseline Actuals Adjustment | 1d | 2013-08-30 A | 2013-08-30 A |  | 100% |  | 2013-09-03 | 2013-09-03 |  |  |  | PROCUREMENT>$50K 69 NO ESCALATION |  |  |  |  | 0 |  |  |  |  |  |  |  |  |  |  |  |  |  |  |  |  |  |  |  |  |  |  |  |  |  |  |  |  |  |  | ADJ |  |  |  |  |  |  |  |  |  |
| 2811001 |  | Accel ARR Process | 44d | 2013-09-03 A | 2013-10-31 A | 2812000 FS-67d, 2811000 FS-60d | 100% |  | 2013-10-16 | 2013-12-18 |  |  | 8/5 M-F w/JLAB Holidays ReBaseline |  |  |  |  |  | 0 | HARWOOD L | 1 | 1 |  | Z | LEIGH H |  |  |  | 2811001 |  |  | 11-026 | 12-025 | PR | 12-029F |  |  |  |  |  |  |  |  |  |  |  |  | ACCL |  |  | 13-015 |  |  |  |  |  |  |  |  |
| 2811000 |  | Accel Hot Check-out | 38d | 2013-10-15 A | 2013-12-09 | 4A-10M |  | 25d | 2013-11-01 | 2014-01-07 | 62d | 35d | 8/5 M-F w/JLAB Holidays ReBaseline | COMP SCIENT [480 h]; MECH TECH [400 h]; MECH ENG [160 h]; SCIENTIST [80 h]; ELEC ENG [240 h]; ELEC TECH [1728 h] | 169,657.12 | 58,040.6 |  |  | 0 | HARWOOD L | 1 | 1 |  | S | LEIGH H | 09-012 |  |  | 2811000 |  |  | 11-026 | 12-025 | PR | 12-029F |  |  |  |  |  |  |  |  |  |  |  |  |  |  |  | 13-015 | ST | 12-040 | PE | 14-001 |  |  |  |  |
| 2811005 |  | Accel Beam Commisioning | 25d | 2013-11-13 | 2013-12-19 | 32-05M |  |  |  |  | 19d | 0d | 8/5 M-F w/JLAB Holidays ReBaseline | COMP SCIENT [1600 h]; MECH ENG [400 h]; MECH TECH [600 h]; ELEC ENG [600 h]; ELEC TECH [3720 h]; SCIENTIST [600 h] | 435,040.8 |  |  |  | 0 | HARWOOD L | 1 | 1 |  | S | LEIGH H | 09-012 |  |  | 2811005 |  |  | 11-026 | 12-025 | PR | 12-029F |  |  |  |  |  |  |  |  |  |  |  |  |  |  |  | 13-015 | ST |  | PE | 14-001 |  |  |  |  |
| 2811019 |  | H-A ARR Process | 20d | 2014-01-02 | 2014-01-30 | 2-08M, 3A-43M |  |  |  |  | 39d | 18d | 8/5 M-F w/JLAB Holidays ReBaseline |  |  |  |  |  | 0 | HARWOOD L | 1 | 1 |  | Z | LEIGH H |  |  |  | 2811019 |  |  | 11-026 |  | PR |  |  |  |  |  |  |  |  |  |  |  |  |  | ACCL | 12-035 |  | 13-015 |  |  |  |  |  |  |  |  |
| 2811020 |  | H-A Beam Cmmssng | 3d | 2014-03-10 | 2014-03-12 | 23613050, 23643175M, 4A-06M, 3P-12M, 23427067, 4A-11M FS-40d, 2367050 |  |  |  |  | 13d | 0d | 8/5 M-F w/JLAB Holidays ReBaseline | SCIENTIST [60 h]; MECH TECH [40 h]; ELEC ENG [20 h]; ELEC TECH [332 h]; MECH ENG [20 h]; COMP SCIENT [40 h] | 27,795.08 |  |  |  | 0 | HARWOOD L | 1 | 1 |  | S | LEIGH H | 09-012 |  |  | 2811020 |  |  | 11-026 | 12-025 | PR |  |  |  |  |  |  |  |  |  |  |  |  |  |  |  |  | 13-015 |  |  | PE | 14-001 |  |  |  |  |
| 2811064 |  | H-D ARR Process | 75d | 2014-08-05 | 2014-11-18 | 3A-53M, 2-12M FS-40d |  |  |  |  | 8d | 0d | 8/5 M-F w/JLAB Holidays ReBaseline |  |  |  |  |  | 0 | HARWOOD L | 1 | 1 |  | Z | LEIGH H |  |  |  | 2811064 | 09-028 | 09-028 | 11-026 |  | PR |  |  |  | 11-006 | 12-021 | 13-007 |  |  |  |  |  |  |  | ACCL |  |  | 13-015 |  |  |  |  | D |  |  |  |
| 2811065 |  | H-D Beam Cmmssng | 15d | 2014-11-19 | 2014-12-11 | 3P-16M |  |  |  |  | 8d | 0d | 8/5 M-F w/JLAB Holidays ReBaseline | COMP SCIENT [240 h]; SCIENTIST [360 h]; ELEC ENG [120 h]; MECH TECH [240 h]; ELEC TECH [1992 h]; MECH ENG [120 h] | 166,770.48 |  |  |  | 0 | HARWOOD L | 1 | 1 |  | S | LEIGH H | 09-012 |  |  | 2811065 | 09-028 | 09-028 | 11-026 |  | PR |  |  |  | 11-006 | 12-021 | 13-007 |  |  |  |  |  |  |  |  |  |  | 13-015 |  |  | PE | 14-001 | D | 09-014 |  |  |
| 2811049 |  | H-C ARR Process | 40d | 2015-11-24 | 2016-02-01 | 2-32M FS-20d, 3A-46M |  |  |  |  | 38d | 0d | 8/5 M-F w/JLAB Holidays ReBaseline |  |  |  |  |  | 0 | HARWOOD L | 1 | 1 |  | Z | LEIGH H |  |  |  | 2811049 | 09-028 | 09-028 | 11-026 |  | PR |  |  |  |  |  |  | 12-012 | 12-036 | 12-054 | 13-006 |  |  |  | ACCL |  |  | 13-015 |  |  |  |  |  |  | 11-046 |  |
| 2811050 |  | H-C Beam Cmmssng | 5d | 2016-02-02 | 2016-02-08 | 32-05M, 3P-18M |  |  |  |  | 38d | 0d | 8/5 M-F w/JLAB Holidays ReBaseline | ELEC ENG [40 h]; MECH ENG [40 h]; COMP SCIENT [80 h]; MECH TECH [80 h]; SCIENTIST [120 h]; ELEC TECH [664 h] | 55,590.16 |  |  |  | 0 | HARWOOD L | 1 | 1 |  | S | LEIGH H | 09-012 |  |  | 2811050 | 09-028 | 09-028 | 11-026 |  | PR |  |  |  |  |  |  | 12-012 | 12-036 | 12-054 | 13-006 |  |  |  |  |  |  | 13-015 |  |  | PE | 14-001 |  |  |  |  |
| 2811034 |  | H-B ARR Process | 40d | 2016-04-15 | 2016-06-10 | 3A-44M, 2-36M FS-20d |  |  |  |  | -60d | 0d | 8/5 M-F w/JLAB Holidays ReBaseline |  |  |  |  |  | 0 | HARWOOD L | 1 | 1 |  | Z | LEIGH H |  |  |  | 2811034 |  |  | 11-026 |  | PR |  |  |  |  |  |  |  |  |  |  | 12-024 | 13-002 | 13-010 | ACCL |  |  | 13-015 |  |  |  |  |  |  |  | 11 -035 |
| 2811035 |  | H-B Beam Cmmssng | 10d | 2016-06-13 | 2016-06-24 | 3P-20M |  |  |  |  | -60d | 0d | 8/5 M-F w/JLAB Holidays ReBaseline | ELEC ENG [80 h]; MECH TECH [160 h]; ELEC TECH [1328 h]; MECH ENG [80 h]; COMP SCIENT [160 h]; SCIENTIST [240 h] | 111,180.32 |  |  |  | 0 | HARWOOD L | 1 | 1 |  | S | LEIGH H | 09-012 |  |  | 2811035 | 09-028 | 09-028 | 11-026 |  | PR |  |  |  |  |  |  |  |  |  |  | 12-024 | 13-002 | 13-010 |  |  |  | 13-015 |  |  | PE | 14-001 |  |  |  |  |

Notes:
- 2811000: Steps: linacs - operate with 250MV from C100's in NL; linacs - operate with 250MV from C100's in LL; linacs - operate with 500MV from C100's in NL; linacs - operate with 500MV from C100's in LL; linacs - operate NL at settings for 0.5 GeV/pass; linacs - operate SL at settings for 0.5 GeV/pass; linacs - operate NL at settings for 1.1 GeV/pass; linacs - operate SL at settings for 1.1 GeV/pass; linacs - operate NL at settings for 2.2 GeV/pass; linacs - operate SL at settings for 2.2 GeV/pass
- 2811005: Steps: Transport beam to end of Pre-chicane (0L02 ¿ 0L10); Transport beam to end of Chicane (0L10 ¿ 0R08); Transport beam to end of North Linac (0R09 ¿ 1L28); Transport beam to end of Arc 1 (1L28 ¿ 1R02); Calibrate the gradient of each of the 1L02 ¿ 1L28 RF cavities using 1A arc as the reference.; Transport beam to end of South Linac (1R03 ¿ 2L28); Transport beam to end of Arc 2 (2L28 ¿ 2R02); Calibrate the gradient of each of the 2L02 ¿ 2L28 SRF cavities.; Est. and maintain >2nA beam with 2.2GeV/pass for at least 8h with trip rates no > than those permitted for beam del for

| ID | WBS | Activity | Duration | Start | Finish | Predecessors | Complete | Remaining | Planned start | Planned finish | Total float | Free float | Calendar | Resources | Cost | Actual cost | Original Activity ID Rebaseline | Remaining Material Cost Based on % Compl | Claimed Material Cost Based on % Complet | Initial Claimed Material Calc | Claimed Material Divider | MONTHLY EV COST | RESP - Responsibility | STRT%COMP for CM EVM | FNSH%COMP for CM EVM | Advance Purchase Plan > 500K | EVMS Reporting Codes | CAM RESPONSIBLE | Activities with Steps | CR 11-026 | CR 12-025 | CR 12-029 | CR 12-040 | BOE Procurement | BOE Labor | CR 13-015 | Post Rebaseline | Temple/Lehman | CR 14-001 | CR 09-012 | HALL D Related Milestones | CR 09-014 | CR 09-028 | CR 09-028 Repair | CR 11-006 | CR 12-021 | CR 13-007 | CR 08-016 | CR 12-012 | CR 12-036 | CR 12-054 | CR 13-006 | CR 12-024 | CR 13-002 | CR 13-010 | Specification | Calculated Remaining Total Cost | CR 08-050 | CR 10-031 | CR 10-064 | CR 10-066 | CR 12-018 | CR 12-028 | ReBaseline Actuals Adjustment | PRIOR MONTH EV COST | BOE Expenses | BOE Adder | CR 08-009 | CR 10-028 | CR 13-009 | MARCH!!! | CR 13-003 |
| --- | --- | --- | --- | --- | --- | --- | --- | --- | --- | --- | --- | --- | --- | --- | --- | --- | --- | --- | --- | --- | --- | --- | --- | --- | --- | --- | --- | --- | --- | --- | --- | --- | --- | --- | --- | --- | --- | --- | --- | --- | --- | --- | --- | --- | --- | --- | --- | --- | --- | --- | --- | --- | --- | --- | --- | --- | --- | --- | --- | --- | --- | --- | --- | --- | --- | --- | --- | --- | --- | --- | --- | --- |
|  | 2 | **1.8.1.2 CONSTRUCTION ACCELERATOR PRE-OPS UTILITIES** |  | 2013-10-15 | 2016-06-24 |  |  |  |  |  |  |  |  |  |  |  |  |  |  |  |  |  |  |  |  |  |  |  |  |  |  |  |  |  |  |  |  |  |  |  |  |  |  |  |  |  |  |  |  |  |  |  |  |  |  |  |  |  |  |  |  |  |  |  |  |  |  |  |  |  |  |  |
| 2812000 |  | Accel Hot Check-out Accelerator Commissioning (Utilities) | 20d | 2013-10-15 A | 2013-11-27 | 4A-10M FS-40d |  | 19d | 2013-11-01 | 2013-12-02 | 75d | 48d | 8/5 M-F w/JLAB Holidays ReBaseline | PROCUREMENT>$50K 69; SR STAFF [102.4 h]; ELEC ENG [102.4 h]; ELEC TECH [102.4 h]; MECH ENG [102.4 h]; MECH TECH [102.4 h] | 235,442.44 | 15,160.28 | 2812000 | 198124.8 | 0 | 0 | 100 | 0 | HARWOOD L | 1 | 1 | APP | S | LEIGH H | ST | 11-026 | 12-025 | 12-029F | 12-040 | PE | PE | 13-015 | PR | LR13 | 14-001 |  |  |  |  |  |  |  |  |  |  |  |  |  |  |  |  |  |  |  |  |  |  |  |  |  |  |  |  |  |  |  |  |  |
| 2812005 |  | Accel Beam Commissioning (Utilities) | 25d | 2013-11-13 | 2013-12-19 | 32-05M |  |  |  |  | 19d | 0d | 8/5 M-F w/JLAB Holidays ReBaseline | MECH TECH [256.8 h]; PROCUREMENT>$50K 69; SR STAFF [256.8 h]; ELEC ENG [256.8 h]; ELEC TECH [256.8 h]; MECH ENG [256.8 h] | 703,438.53 |  | 2812005 | 609852.9 | 0 | 0 | 100 | 0 | HARWOOD L | 1 | 1 | APP | S | LEIGH H | ST | 11-026 | 12-025 | 12-029F |  | PE | PE | 13-015 | PR | LR13 | 14-001 | 09-012 |  |  |  |  |  |  |  |  |  |  |  |  |  |  |  |  |  |  |  |  |  |  |  |  |  |  |  |  |  |  |  |  |
| 2812065 |  | H-A Beam Cmmssng (Utilities) | 3d | 2014-02-26 | 2014-02-28 | 3P-12M |  |  |  |  | 21d | 8d | 8/5 M-F w/JLAB Holidays ReBaseline | PROCUREMENT>$50K 69; MECH TECH [31 h]; MECH ENG [31 h]; ELEC ENG [31 h]; ELEC TECH [31 h] | 123,140.21 |  | 2812065 | 115572.8 | 0 | 0 | 100 | 0 | HARWOOD L | 1 | 1 | APP | S | LEIGH H |  | 11-026 | 12-025 |  |  | PE | PE | 13-015 | PR | LR13 | 14-001 | 09-012 |  |  |  |  |  |  |  |  |  |  |  |  |  |  |  |  |  |  |  |  |  |  |  |  |  |  |  |  |  |  |  |  |
| 2812050 |  | H-D Beam Cmmssng (Utilities) | 15d | 2014-11-19 | 2014-12-11 | 3P-16M |  |  |  |  | 8d | 0d | 8/5 M-F w/JLAB Holidays ReBaseline | MECH ENG [185 h]; ELEC ENG [185 h]; ELEC TECH [185 h]; PROCUREMENT>$50K 69; MECH TECH [185 h] | 599,290.65 |  | 2812050 | 554130.3 | 0 | 0 | 100 | 0 | HARWOOD L | 1 | 1 | APP | S | LEIGH H |  | 11-026 |  |  |  | PE | PE | 13-015 | PR | LR13 | 14-001 | 09-012 | D | 09-014 | 09-028 | 09-028 | 11-006 | 12-021 | 13-007 |  |  |  |  |  |  |  |  |  |  |  |  |  |  |  |  |  |  |  |  |  |  |  |  |  |
| 2812035 |  | H-C Beam Cmmssng (Utilities) | 5d | 2016-02-02 | 2016-02-08 | 3P-18M |  |  |  |  | 38d | 0d | 8/5 M-F w/JLAB Holidays ReBaseline | MECH ENG [63 h]; ELEC TECH [63 h]; MECH TECH [63 h]; ELEC ENG [63 h]; PROCUREMENT>$50K 69 | 276,449.63 |  | 2812035 | 261070.7 | 0 | 0 | 100 | 0 | HARWOOD L | 1 | 1 | APP | S | LEIGH H |  | 11-026 |  |  |  | PE | PE | 13-015 | PR | LR13 | 14-001 | 09-012 |  |  | 09-028 | 09-028 |  |  |  | 08-016 | 12-012 | 12-036 | 12-054 | 13-006 |  |  |  |  |  |  |  |  |  |  |  |  |  |  |  |  |  |  |  |  |
| 2812020 |  | H-B Beam Cmmssng (Utilities) | 10d | 2016-06-13 | 2016-06-24 | 3P-20M |  |  |  |  | -60d | 0d | 8/5 M-F w/JLAB Holidays ReBaseline | PROCUREMENT>$50K 69; ELEC TECH [123 h]; MECH TECH [123 h]; ELEC ENG [123 h]; MECH ENG [123 h] | 398,413.83 |  | 2812020 | 368388.3 | 0 | 0 | 100 | 0 | HARWOOD L | 1 | 1 | APP | S | LEIGH H |  | 11-026 |  |  |  | PE | PE | 13-015 | PR | LR13 | 14-001 | 09-012 |  |  | 09-028 | 09-028 |  |  |  | 08-016 |  |  |  |  | 12-024 | 13-002 | 13-010 |  |  |  |  |  |  |  |  |  |  |  |  |  |  |  |  |  |
|  | 3 | **1.8.1.3 ACCELERATOR PRE-OPS CHECKOUT** |  | 2012-12-17 | 2014-06-25 |  |  |  |  |  |  |  |  |  |  |  |  |  |  |  |  |  |  |  |  |  |  |  |  |  |  |  |  |  |  |  |  |  |  |  |  |  |  |  |  |  |  |  |  |  |  |  |  |  |  |  |  |  |  |  |  |  |  |  |  |  |  |  |  |  |  |  |
|  | 1 | **1.8.1.3.1 CRYOMODULES ACCELERATOR PRE-OPS** |  | 2013-04-01 | 2014-02-28 |  |  |  |  |  |  |  |  |  |  |  |  |  |  |  |  |  |  |  |  |  |  |  |  |  |  |  |  |  |  |  |  |  |  |  |  |  |  |  |  |  |  |  |  |  |  |  |  |  |  |  |  |  |  |  |  |  |  |  |  |  |  |  |  |  |  |  |
|  | 5 | **1.8.1.3.1.5 CRYOMODULES IN-TUNNEL CHECKOUT** |  | 2013-04-01 | 2014-02-28 |  |  |  |  |  |  |  |  |  |  |  |  |  |  |  |  |  |  |  |  |  |  |  |  |  |  |  |  |  |  |  |  |  |  |  |  |  |  |  |  |  |  |  |  |  |  |  |  |  |  |  |  |  |  |  |  |  |  |  |  |  |  |  |  |  |  |  |
| 181315000 |  | In-Tunnel Checkout and Commisioning Cryomodule #3 5th | 35d | 2013-04-01 A | 2013-05-17 A | 181321000, 132122025M, 131503000, 131505005 FS+121d | 100% |  | 2013-05-01 | 2013-06-19 |  |  |  | SR STAFF [40 h]; COMP SCIENT [16 h]; ELEC ENG [240 h]; ELEC TECH [120 h]; SUPPLIES & MATERIALS; SCIENTIST [40 h]; MECH ENG [80 h]; MECH TECH [160 h] | 50,221.29 | 44,727.36 |  |  |  |  |  | 50221.29 | HOGAN J | 1 | 1 |  | S | JOHN H | ST |  |  |  | 12-040 |  |  |  |  |  |  |  |  |  |  |  |  |  |  |  |  |  |  |  |  |  |  | 181315000 | 0 | 08-050 | 10-031 | 10-064 | 10-066 | 12-018 | 12-028 |  |  |  |  |  |  |  |  |  |
| 181315005 |  | In-Tunnel Checkout and Commisioning Cryomodule #6 | 73d | 2013-04-01 A | 2013-07-15 A | 181315010 FS-55d, 131506000, 181321005 FS-15d | 100% |  | 2013-05-01 | 2013-08-13 |  |  |  | SCIENTIST [40 h]; ELEC ENG [240 h]; ELEC TECH [120 h]; COMP SCIENT [16 h]; MECH ENG [80 h]; SR STAFF [40 h]; MECH TECH [160 h]; SUPPLIES & MATERIALS | 50,221.29 | 44,727.36 |  |  |  |  |  | 50221.29 | HOGAN J | 1 | 1 |  | S | JOHN H | ST |  |  |  | 12-040 |  |  |  |  |  |  |  |  |  |  |  |  |  |  |  |  |  |  |  |  |  |  | 181315005 | 17577.4515 | 08-050 | 10-031 | 10-064 | 10-066 | 12-018 | 12-028 |  |  |  |  |  |  |  |  |  |
| 181315010 |  | In-Tunnel Checkout and Commisioning Cryomodule #7 | 54d | 2013-04-01 A | 2013-06-20 A | 181315000 FS-35d, 131507000, 181321010 FS-20d | 100% |  | 2013-05-01 | 2013-07-17 |  |  |  | SUPPLIES & MATERIALS; SCIENTIST [40 h]; SR STAFF [40 h]; MECH TECH [160 h]; COMP SCIENT [16 h]; ELEC ENG [240 h]; ELEC TECH [120 h]; MECH ENG [80 h] | 50,221.29 | 44,727.36 |  |  |  |  |  | 50221.29 | HOGAN J | 1 | 1 |  | S | JOHN H | ST |  |  |  | 12-040 |  |  |  |  |  |  |  |  |  |  |  |  |  |  |  |  |  |  |  |  |  |  | 181315010 | 0 | 08-050 | 10-031 | 10-064 | 10-066 | 12-018 | 12-028 |  |  |  |  |  |  |  |  |  |
| 181315015 |  | In-Tunnel Checkout and Commisioning Cryomodule #8 | 83d | 2013-05-03 A | 2013-08-30 A | 181315005 FS-75d, 181321015 FS-70d, 131508000 FS-45d | 100% |  | 2013-06-03 | 2013-09-27 |  |  |  | ELEC ENG [240 h]; COMP SCIENT [16 h]; SR STAFF [40 h]; MECH ENG [80 h]; MECH TECH [160 h]; SUPPLIES & MATERIALS; SCIENTIST [40 h]; ELEC TECH [120 h] | 50,221.29 | 44,727.36 |  |  |  |  |  | 50221.29 | HOGAN J | 1 | 1 |  | S | JOHN H | ST |  |  |  | 12-040 |  |  |  |  |  |  |  |  |  |  |  |  |  |  |  |  |  |  |  |  |  |  | 181315015 | 35154.903 | 08-050 | 10-031 | 10-064 | 10-066 | 12-018 | 12-028 |  |  |  |  |  |  |  |  |  |
| 181315020 |  | In-Tunnel Checkout and Commisioning Cryomodule #9 | 44d | 2013-05-03 A | 2013-08-16 A | 181315015 FS-95d, 131509000 FS+6d, 181321020 FS-95d | 100% |  | 2013-06-03 | 2013-08-02 |  |  |  | MECH TECH [160 h]; SCIENTIST [40 h]; SR STAFF [40 h]; SUPPLIES & MATERIALS; ELEC ENG [240 h]; ELEC TECH [120 h]; COMP SCIENT [16 h]; MECH ENG [80 h] | 50,221.29 | 44,727.36 |  |  |  |  |  | 50221.29 | HOGAN J | 1 | 1 |  | S | JOHN H | ST |  |  |  | 12-040 |  |  |  |  |  |  |  |  |  |  |  |  |  |  |  |  |  |  |  |  |  |  | 181315020 | 35154.903 | 08-050 | 10-031 | 10-064 | 10-066 | 12-018 | 12-028 |  |  |  |  |  |  |  |  |  |
| 181315025 |  | In-Tunnel Checkout and Commisioning Cryomodule #10 | 27d | 2013-07-15 A | 2013-08-30 A | 181321025 FS-45d, 131510000, 181315020 FS-13d | 100% |  | 2013-08-02 | 2013-09-10 |  |  |  | SUPPLIES & MATERIALS; SCIENTIST [40 h]; SR STAFF [40 h]; ELEC TECH [120 h]; COMP SCIENT [16 h]; MECH TECH [160 h]; MECH ENG [80 h]; ELEC ENG [240 h] | 50,221.29 | 44,727.36 |  |  |  |  |  | 50221.29 | HOGAN J | 1 | 1 |  | S | JOHN H | ST |  |  |  | 12-040 |  |  |  |  |  |  |  |  |  |  |  |  |  |  |  |  |  |  |  |  |  |  | 181315025 | 50221.29 | 08-050 | 10-031 | 10-064 | 10-066 | 12-018 | 12-028 |  |  |  |  |  |  |  |  |  |
| 181315030 |  | Re-Baseline Actuals Adjustment | 1d | 2013-08-30 A | 2013-08-30 A |  | 100% |  | 2013-09-03 | 2013-09-03 |  |  |  | PROCUREMENT>$50K 69 NO ESCALATION | -108,120.57 |  |  |  |  |  | 100 |  |  |  |  |  |  |  |  |  |  |  |  |  |  |  |  |  |  |  |  |  |  |  |  |  |  |  |  |  |  |  |  |  |  |  |  |  |  |  |  |  |  | ADJ |  |  |  |  |  |  |  |  |
| 281315025 |  | In-Tunnel Checkout and Commisioning Cryomodule #10 FY13 | 29d | 2013-09-03 A | 2013-09-23 A | 281321025 FS-5d | 100% |  | 2013-10-01 | 2013-11-08 |  |  | 8/5 M-F w/JLAB Holidays ReBaseline | MECH ENG [12.97 h]; ELEC ENG [38.91 h]; SUPPLIES & MATERIALS; SCIENTIST [6.48 h]; SR STAFF [6.48 h]; ELEC TECH [19.45 h]; COMP SCIENT [2.59 h]; MECH TECH [25.94 h] | 8,808.03 | 7,250.84 | 281315025 |  |  |  |  | 0 | HOGAN J | 1 | 1 |  | S | JOHN H | ST |  |  |  | 12-040 | PE | PE | 13-015 | PR |  |  |  |  |  |  |  |  |  |  |  |  |  |  |  |  |  |  |  |  | 08-050 | 10-031 | 10-064 | 10-066 | 12-018 | 12-028 |  | 8576.964889 | PE | YES |  |  |  |  |  |
| 281315025a |  | In-Tunnel Checkout and Commisioning Cryomodule #10 FY14 | 9d | 2013-09-03 A | 2013-09-23 A | 281315025 | 100% |  | 2013-10-01 | 2013-10-11 |  |  | 8/5 M-F w/JLAB Holidays ReBaseline | MECH ENG [5.84 h]; ELEC ENG [17.51 h]; SUPPLIES & MATERIALS; SCIENTIST [2.92 h]; SR STAFF [2.92 h]; ELEC TECH [8.75 h]; COMP SCIENT [1.17 h]; MECH TECH [11.67 h] | 3,982.42 | 3,262.66 | 281315025 |  |  |  |  | 0 | HOGAN J | 1 | 1 |  | S | JOHN H | ST |  |  |  | 12-040 | PE | PE | 13-015 | PR |  | 14-001 |  |  |  |  |  |  |  |  |  |  |  |  |  |  |  |  |  |  | 08-050 | 10-031 | 10-064 | 10-066 | 12-018 | 12-028 |  | 3982.428662 | PE | YES |  |  |  |  |  |
| 281315030 |  | Installation & Test of Individual Heater Control & Piezo Operation FY13 | 118d | 2013-09-03 A | 2014-02-28 | 9-130M FS+228d | 30% | 75d | 2013-10-01 | 2014-03-28 | 207d | 23d | 8/5 M-F w/JLAB Holidays ReBaseline | MECH ENG [4.68 h]; ELEC ENG [14.03 h]; SUPPLIES & MATERIALS; SCIENTIST [2.34 h]; SR STAFF [2.34 h]; ELEC TECH [7.01 h]; COMP SCIENT [0.94 h]; MECH TECH [9.35 h] | 3,023.46 | 968.88 | 281315025 |  |  |  |  | 441.02205165 | HOGAN J | 1 | 1 |  | S | JOHN H | ST |  |  |  |  |  |  |  | PR |  |  |  |  |  |  |  |  |  |  |  |  |  |  |  |  |  |  |  |  |  |  |  |  |  |  |  | 441.02205165 |  |  |  |  |  |  |  |
| 281315030a |  | Installation & Test of Individual Heater Control & Piezo Operation FY14 | 98d | 2013-09-03 A | 2014-02-28 | 281315030 FS-98d | 30% | 75d | 2013-10-01 | 2014-02-28 | 207d |  | 8/5 M-F w/JLAB Holidays ReBaseline | MECH ENG [22.91 h]; ELEC ENG [68.73 h]; SUPPLIES & MATERIALS; SCIENTIST [11.46 h]; SR STAFF [11.46 h]; ELEC TECH [34.37 h]; COMP SCIENT [4.58 h]; MECH TECH [45.82 h] | 14,865.11 | 4,747.24 | 281315025 |  |  |  |  | 2229.76411545 | HOGAN J | 1 | 1 |  | S | JOHN H | ST |  |  |  |  |  |  | 13-015 | PR |  | 14-001 |  |  |  |  |  |  |  |  |  |  |  |  |  |  |  |  |  |  |  |  |  |  |  |  |  | 2229.76411545 |  |  |  |  |  |  |  |
| 281315015 |  | In-Tunnel Checkout and Commisioning Cryomodule #8 | 14d | 2013-10-01 A | 2013-11-20 | 9-130M FS+228d | 50% | 14d | 2013-11-01 | 2013-11-20 | 24d | 0d | 8/5 M-F w/JLAB Holidays ReBaseline | ELEC ENG [112.83 h]; COMP SCIENT [7.52 h]; SR STAFF [18.8 h]; MECH ENG [37.61 h]; MECH TECH [75.22 h]; SUPPLIES & MATERIALS; SCIENTIST [18.8 h]; ELEC TECH [56.41 h] | 25,542.83 | 13,487.37 | 281315015 |  |  |  |  | 12436.3751435 | HOGAN J | 1 | 1 |  | S | JOHN H | ST |  |  |  | 12-040 | PE | PE | 13-015 | PR |  |  |  |  |  |  |  |  |  |  |  |  |  |  |  |  |  |  |  |  | 08-050 | 10-031 | 10-064 | 10-066 | 12-018 | 12-028 |  |  | PE | YES |  |  |  |  |  |
|  | 2 | **1.8.1.3.2 POWER PRE-OPS CHECKOUT** |  | 2013-01-15 | 2014-06-25 |  |  |  |  |  |  |  |  |  |  |  |  |  |  |  |  |  |  |  |  |  |  |  |  |  |  |  |  |  |  |  |  |  |  |  |  |  |  |  |  |  |  |  |  |  |  |  |  |  |  |  |  |  |  |  |  |  |  |  |  |  |  |  |  |  |  |  |
|  | 1 | **1.8.1.3.2.1 RF PRE-OPS CHECKOUT** |  | 2013-01-15 | 2013-12-13 |  |  |  |  |  |  |  |  |  |  |  |  |  |  |  |  |  |  |  |  |  |  |  |  |  |  |  |  |  |  |  |  |  |  |  |  |  |  |  |  |  |  |  |  |  |  |  |  |  |  |  |  |  |  |  |  |  |  |  |  |  |  |  |  |  |  |  |
| 181321000 |  | RF Sys Tests #5 (Install & SYS COMMIS) | 11d | 2013-01-15 A | 2013-02-15 A | 132112085M FS-36d, 132121065M | 100% |  | 2013-02-01 | 2013-02-15 |  |  |  | ELEC ENG [16 h]; ELEC TECH [100 h]; COMP SCIENT [16 h]; OFFICE [8 h]; SUPPLIES & MATERIALS; ELEC DES [56 h] | 10,216.3 | 9,956.72 |  |  |  |  |  | 10216.3 | HOVATER C | 1 | 1 |  | S | BILL M | ST |  |  |  | 12-040 |  |  |  |  |  |  |  |  |  |  |  |  |  |  |  |  |  |  |  |  |  |  | 181321000 | 0 |  | 10-031 |  | 10-066 | 12-018 | 12-028 |  |  |  |  | 08-009 | 10-028 | 13-009F | XX |  |
| 181321005 |  | RF Sys Tests #6 (Install & SYS COMMIS) | 11d | 2013-03-04 A | 2013-04-15 A | 132112086M FS-20d, 132121066M | 100% |  | 2013-04-01 | 2013-04-15 |  |  |  | OFFICE [8 h]; SUPPLIES & MATERIALS; ELEC DES [56 h]; ELEC ENG [16 h]; ELEC TECH [100 h]; COMP SCIENT [16 h] | 10,216.3 | 9,956.72 |  |  |  |  |  | 10216.3 | HOVATER C | 1 | 1 |  | S | BILL M | ST |  |  |  | 12-040 |  |  |  |  |  |  |  |  |  |  |  |  |  |  |  |  |  |  |  |  |  |  | 181321005 | 0 |  | 10-031 |  | 10-066 | 12-018 | 12-028 |  |  |  |  | 08-009 | 10-028 | 13-009 | XX |  |
| 181321010 |  | RF Sys Tests #7 (Install & SYS COMMIS) | 6d | 2013-03-11 A | 2013-06-17 A | 132112087M FS-30d, 132121067M | 100% |  | 2013-04-18 | 2013-04-25 |  |  |  | ELEC ENG [16 h]; ELEC TECH [100 h]; COMP SCIENT [16 h]; OFFICE [8 h]; SUPPLIES & MATERIALS; ELEC DES [56 h] | 10,216.3 | 9,956.72 |  |  |  |  |  | 10216.3 | HOVATER C | 1 | 1 |  | S | BILL M | ST |  |  |  | 12-040 |  |  |  |  |  |  |  |  |  |  |  |  |  |  |  |  |  |  |  |  |  |  | 181321010 | 0 |  | 10-031 |  | 10-066 | 12-018 | 12-028 |  |  |  |  | 08-009 | 10-028 | 13-009 | XX |  |
| 181321030 |  | RF Cavity Tests Cryomodule #3 (Install & SYS COMMIS) | 18d | 2013-04-15 A | 2013-06-17 A | 181321000, 181315000 FS-40d | 100% |  | 2013-06-20 | 2013-07-16 |  |  |  | OFFICE [8 h]; SUPPLIES & MATERIALS; ELEC ENG [56 h]; ELEC DES [64 h]; ELEC TECH [60 h]; SCIENTIST [16 h] | 11,805.25 | 11,546.88 |  |  |  |  |  | 11805.25 | HOVATER C | 1 | 1 |  | S | BILL M | ST |  |  |  | 12-040 |  |  |  |  |  |  |  |  |  |  |  |  |  |  |  |  |  |  |  |  |  |  | 181321030 | 0 |  |  |  | 10-066 | 12-018 | 12-028 |  |  |  |  | 08-009 |  |  |  | 13-003 |
| 181321040 |  | RF Cavity Tests Cryomodule #7 (Install & SYS COMMIS) | 18d | 2013-06-01 A | 2013-06-17 A | 181321010, 181315010 FS-18d | 100% |  | 2013-07-01 | 2013-07-25 |  |  |  | ELEC TECH [60 h]; SCIENTIST [16 h]; OFFICE [8 h]; SUPPLIES & MATERIALS; ELEC ENG [56 h]; ELEC DES [64 h] | 11,805.21 | 11,546.88 |  |  |  |  |  | 11805.21 | HOVATER C | 1 | 1 |  | S | BILL M | ST |  |  |  | 12-040 |  |  |  |  |  |  |  |  |  |  |  |  |  |  |  |  |  |  |  |  |  |  | 181321040 | 0 |  |  |  | 10-066 | 12-018 | 12-028 |  |  |  |  | 08-009 |  |  |  | 13-003 |
| 181321015 |  | RF Sys Tests #8 (Install & SYS COMMIS) | 15d | 2013-06-09 A | 2013-07-15 A | 132121068M, 132112088M FS-10d | 100% |  | 2013-07-09 | 2013-07-29 |  |  |  | ELEC DES [56 h]; ELEC ENG [16 h]; ELEC TECH [100 h]; COMP SCIENT [16 h]; OFFICE [8 h]; SUPPLIES & MATERIALS | 10,216.3 | 9,956.72 |  |  |  |  |  | 10216.3 | HOVATER C | 1 | 1 |  | S | BILL M | ST |  |  |  | 12-040 |  |  |  |  |  |  |  |  |  |  |  |  |  |  |  |  |  |  |  |  |  |  | 181321015 | 0 |  | 10-031 |  | 10-066 | 12-018 | 12-028 |  |  |  |  | 08-009 | 10-028 | 13-009 |  |  |
| 181321035 |  | RF Cavity Tests Cryomodule #6 (Install & SYS COMMIS) | 18d | 2013-06-10 A | 2013-07-15 A | 181315005 FS-18d, 181321005 | 100% |  | 2013-07-01 | 2013-07-25 |  |  |  | ELEC ENG [56 h]; ELEC DES [64 h]; ELEC TECH [60 h]; SCIENTIST [16 h]; OFFICE [8 h]; SUPPLIES & MATERIALS | 11,805.25 | 11,546.88 |  |  |  |  |  | 11805.25 | HOVATER C | 1 | 1 |  | S | BILL M | ST |  |  |  | 12-040 |  |  |  |  |  |  |  |  |  |  |  |  |  |  |  |  |  |  |  |  |  |  | 181321035 | 0 |  |  |  | 10-066 | 12-018 | 12-028 |  |  |  |  | 08-009 |  |  |  | 13-003 |
| 181321020 |  | RF Sys Tests #9 (Install & SYS COMMIS) | 15d | 2013-07-07 A | 2013-08-23 A | 132121069M, 132112089M FS-20d | 100% |  | 2013-08-07 | 2013-08-27 |  |  |  | OFFICE [8 h]; SUPPLIES & MATERIALS; ELEC DES [56 h]; ELEC ENG [16 h]; ELEC TECH [100 h]; COMP SCIENT [16 h] | 10,216.3 | 9,956.72 |  |  |  |  |  | 10216.3 | HOVATER C | 1 | 1 |  | S | BILL M | ST |  |  |  | 12-040 |  |  |  |  |  |  |  |  |  |  |  |  |  |  |  |  |  |  |  |  |  |  | 181321020 | 10216.3 |  | 10-031 |  | 10-066 | 12-018 | 12-028 |  |  |  |  | 08-009 | 10-028 | 13-009 |  |  |
| 181321045 |  | RF Cavity Tests Cryomodule #8 (Install & SYS COMMIS) | 18d | 2013-08-03 A | 2013-08-19 A | 181315015 FS-18d, 181321015 | 100% |  | 2013-09-03 | 2013-09-26 |  |  |  | ELEC DES [64 h]; ELEC TECH [60 h]; SCIENTIST [16 h]; OFFICE [8 h]; SUPPLIES & MATERIALS; ELEC ENG [56 h] | 11,805.25 | 11,546.88 |  |  |  |  |  | 11805.25 | HOVATER C | 1 | 1 |  | S | BILL M | ST |  |  |  | 12-040 |  |  |  |  |  |  |  |  |  |  |  |  |  |  |  |  |  |  |  |  |  |  | 181321045 | 11805.25 |  |  |  | 10-066 | 12-018 | 12-028 |  |  |  |  | 08-009 |  |  |  | 13-003 |
| 181321050 |  | RF Cavity Tests Cryomodule #9 (Install & SYS COMMIS) | 18d | 2013-08-05 A | 2013-08-30 A | 181315020 FS-18d, 181321020 | 100% |  | 2013-09-03 | 2013-09-26 |  |  |  | SCIENTIST [16 h]; OFFICE [8 h]; SUPPLIES & MATERIALS; ELEC ENG [56 h]; ELEC TECH [60 h]; ELEC DES [64 h] | 11,805.25 | 11,546.88 |  |  |  |  |  | 11805.25 | HOVATER C | 1 | 1 |  | S | BILL M | ST |  |  |  | 12-040 |  |  |  |  |  |  |  |  |  |  |  |  |  |  |  |  |  |  |  |  |  |  | 181321050 | 11805.25 |  |  |  | 10-066 | 12-018 | 12-028 |  |  |  |  | 08-009 |  |  |  | 13-003 |
| 181321025 |  | RF Sys Tests #10 (Install & SYS COMMIS) | 15d | 2013-08-19 A | 2013-08-30 A | 132121070M, 132112090M FS-15d | 100% |  | 2013-09-19 | 2013-10-09 |  |  |  | ELEC TECH [100 h]; COMP SCIENT [16 h]; OFFICE [8 h]; SUPPLIES & MATERIALS; ELEC DES [56 h]; ELEC ENG [16 h] | 10,364.31 | 9,956.72 |  |  |  |  |  | 10216.3 | HOVATER C | 1 | 1 |  | S | BILL M | ST |  |  |  | 12-040 |  |  |  |  |  |  |  |  |  |  |  |  |  |  |  |  |  |  |  |  |  |  | 181321025 | 10216.3 |  | 10-031 |  | 10-066 | 12-018 | 12-028 |  |  |  |  | 08-009 | 10-028 | 13-009 |  |  |
| 181321055 |  | RF Cavity Tests Cryomodule #10 (Install & SYS COMMIS) | 15d | 2013-08-30 A | 2013-08-30 A | 181321025, 181315025 FS-18d | 100% |  | 2013-09-10 | 2013-09-30 |  |  |  | ELEC TECH [60 h]; SCIENTIST [16 h]; OFFICE [8 h]; SUPPLIES & MATERIALS; ELEC ENG [56 h]; ELEC DES [64 h] | 11,805.25 | 11,546.88 |  |  |  |  |  | 11805.25 | HOVATER C | 1 | 1 |  | S | BILL M | ST |  |  |  | 12-040 |  |  |  |  |  |  |  |  |  |  |  |  |  |  |  |  |  |  |  |  |  |  | 181321055 | 11805.25 |  |  |  | 10-066 | 12-018 | 12-028 |  |  |  |  | 08-009 |  |  |  | 13-003 |
| 181321060 |  | Re-Baseline Actuals Adjustment | 1d | 2013-08-30 A | 2013-08-30 A |  | 100% |  | 2013-09-03 | 2013-09-03 |  |  |  | PROCUREMENT>$50K 69 NO ESCALATION | -22,855.65 |  |  |  |  |  | 100 |  |  |  |  |  |  |  |  |  |  |  |  |  |  |  |  |  |  |  |  |  |  |  |  |  |  |  |  |  |  |  |  |  |  |  |  |  |  |  |  |  |  | ADJ |  |  |  |  |  |  |  |  |
| 281321025 |  | RF Sys Tests #10 (Install & SYS COMMIS) | 5d | 2013-09-03 A | 2013-09-09 A | 9-130M FS+228d | 100% |  | 2013-10-01 | 2013-10-07 |  |  | 8/5 M-F w/JLAB Holidays ReBaseline | ELEC TECH [60 h]; COMP SCIENT [9.6 h]; OFFICE [4.8 h]; SUPPLIES & MATERIALS; ELEC DES [33.6 h]; ELEC ENG [9.6 h] | 6,320.08 | 5,974.04 | 281321025 |  |  |  |  | 0 | HOVATER C | 1 | 1 |  | H | BILL M |  |  |  |  | 12-040 | PE | PE | 13-015 | PR | LR13 |  |  |  |  |  |  |  |  |  |  |  |  |  |  |  |  |  |  |  |  | 10-031 |  | 10-066 | 12-018 | 12-028 |  | 6129.782 | PE | NO | 08-009 | 10-028 | 13-009 |  |  |
| 281321050 |  | RF Cavity Tests Cryomodule #9 (Install & SYS COMMIS) | 10d | 2013-09-03 A | 2013-12-13 | 9-130M FS+228d | 50% | 29d | 2013-10-01 | 2013-10-14 | 78d | 0d | 8/5 M-F w/JLAB Holidays ReBaseline | SCIENTIST [11.2 h]; OFFICE [5.6 h]; SUPPLIES & MATERIALS; ELEC ENG [39.2 h]; ELEC TECH [42 h]; ELEC DES [44.8 h] | 8,521.14 | 3,299.11 | 281321050 |  |  |  |  | 0 | HOVATER C | 1 | 1 |  | H | BILL M |  |  |  |  | 12-040 | PE | PE | 13-015 | PR |  |  |  |  |  |  |  |  |  |  |  |  |  |  |  |  |  |  |  |  |  |  |  | 10-066 | 12-018 | 12-028 |  | 4131.838 | PE | NO | 08-009 |  |  |  | 13-003 |
| 281321055 |  | RF Cavity Tests Cryomodule #10 (Install & SYS COMMIS) | 18d | 2013-11-01 | 2013-11-26 | 281315025 FS-13d, 281321025 |  |  |  |  | 89d | 11d | 8/5 M-F w/JLAB Holidays ReBaseline | ELEC TECH [60 h]; SCIENTIST [16 h]; OFFICE [8 h]; SUPPLIES & MATERIALS; ELEC ENG [56 h]; ELEC DES [64 h] | 12,181.29 |  | 281321055 |  |  |  |  | 0 | HOVATER C | 1 | 1 |  | S | BILL M | ST |  |  |  | 12-040 | PE | PE | 13-015 | PR |  | 14-001 |  |  |  |  |  |  |  |  |  |  |  |  |  |  |  |  |  |  |  |  |  | 10-066 | 12-018 | 12-028 |  |  | PE | NO | 08-009 |  |  |  | 13-003 |

Notes:
- 2812000: Steps: linacs - operate with 250MV from C100's in NL; linacs - operate with 250MV from C100's in LL; linacs - operate with 500MV from C100's in NL; linacs - operate with 500MV from C100's in LL; linacs - operate NL at settings for 0.5 GeV/pass; linacs - operate SL at settings for 0.5 GeV/pass; linacs - operate NL at settings for 1.1 GeV/pass; linacs - operate SL at settings for 1.1 GeV/pass; linacs - operate NL at settings for 2.2 GeV/pass; linacs - operate SL at settings for 2.2 GeV/pass
- 2812005: Steps: Transport beam to end of Pre-chicane (0L02 ¿ 0L10); Transport beam to end of Chicane (0L10 ¿ 0R08); Transport beam to end of North Linac (0R09 ¿ 1L28); Transport beam to end of Arc 1 (1L28 ¿ 1R02); Calibrate the gradient of each of the 1L02 ¿ 1L28 RF cavities using 1A arc as the reference.; Transport beam to end of South Linac (1R03 ¿ 2L28); Transport beam to end of Arc 2 (2L28 ¿ 2R02); Calibrate the gradient of each of the 2L02 ¿ 2L28 SRF cavities.; Est. and maintain >2nA beam with 2.2GeV/pass for at least 8h with trip rates no > than those permitted for beam del for
- 181315000: Steps: 4k Cooldown (done); 2k Cooldown (done); Low Power Measurements (done); High Power Measurements (done)
- 181315005: Steps: 4k Cooldown (done); 2k Cooldown (done); Low Power Measurements (done); High Power Measurements (done)
- 181315010: Steps: 4k Cooldown (done); 2k Cooldown (done); Low Power Measurements (done); High Power Measurements (done)
- 181315015: Steps: 4k Cooldown (done); 2k Cooldown (done); Low Power Measurements (done); High Power Measurements (done)
- 181315020: Steps: 4k Cooldown (done); 2k Cooldown (done); Low Power Measurements (done); High Power Measurements (done)
- 181315025: Steps: 4k Cooldown (done); 2k Cooldown (done); Low Power Measurements (done); High Power Measurements (done)
- 281315025: Steps: Low Power Measurements (done); High Power Measurements (done)
- 281315025a: Steps: Low Power Measurements (done); High Power Measurements (done)
- 281315030: Steps: Change existing system from 4 to 8 heater operation (done); Install piezo actuators for LLRF testing (done); Setup heater controls for individual operation; Operate heater controls for individual compensation; Operate piezos with LLRF; Complete control system checkout
- 281315030a: Steps: Change existing system from 4 to 8 heater operation (done); Install piezo actuators for LLRF testing (done); Setup heater controls for individual operation; Operate heater controls for individual compensation; Operate piezos with LLRF; Complete control system checkout
- 281315015: Steps: Low Power Measurements (done); High Power Measurements
- 181321000: Steps: Waveguide assy/install from WG short to the Cryomodule (Installation and hook up of all the pieces from the Short to CM) (done); Cable connections to the Cryomodule and any system control or interlock checks (done); RF calibrations of cables or signals assc with preparing for CM operation not completed during RF Test in to Shorts (done)
- 181321005: Steps: Waveguide assy/install from WG short to the Cryomodule (Installation and hook up of all the pieces from the Short to CM) (done); Cable connections to the Cryomodule and any system control or interlock checks (done); RF calibrations of cables or signals assc with preparing for CM operation not completed during RF Test in to Shorts (done)
- 181321010: Steps: Waveguide assy/install from WG short to the Cryomodule (Installation and hook up of all the pieces from the Short to CM) (done); Cable connections to the Cryomodule and any system control or interlock checks (done); RF calibrations of cables or signals assc with preparing for CM operation not completed during RF Test in to Shorts (done)
- 181321030: Steps: Repairs and support of the RF system during CM measurements by SRF (Q, Emax, FE threshold, etc.) (done); Post CM commissioning RF system optimization and calibration prior to turn over for OPS (done)
- 181321040: Steps: Repairs and support of the RF system during CM measurements by SRF (Q, Emax, FE threshold, etc.) (done); Post CM commissioning RF system optimization and calibration prior to turn over for OPS (done)
- 181321015: Steps: Waveguide assy/install from WG short to the Cryomodule (Installation and hook up of all the pieces from the Short to CM) (done); Cable connections to the Cryomodule and any system control or interlock checks (done); RF calibrations of cables or signals assc with preparing for CM operation not completed during RF Test in to Shorts (done)
- 181321035: Steps: Repairs and support of the RF system during CM measurements by SRF (Q, Emax, FE threshold, etc.) (done); Post CM commissioning RF system optimization and calibration prior to turn over for OPS (done)
- 181321020: Steps: Waveguide assy/install from WG short to the Cryomodule (Installation and hook up of all the pieces from the Short to CM) (done); Cable connections to the Cryomodule and any system control or interlock checks (done); RF calibrations of cables or signals assc with preparing for CM operation not completed during RF Test in to Shorts (done)
- 181321045: Steps: Repairs and support of the RF system during CM measurements by SRF (Q, Emax, FE threshold, etc.) (done); Post CM commissioning RF system optimization and calibration prior to turn over for OPS (done)
- 181321050: Steps: Repairs and support of the RF system during CM measurements by SRF (Q, Emax, FE threshold, etc.) (done); Post CM commissioning RF system optimization and calibration prior to turn over for OPS (done)
- 181321025: Steps: Waveguide assy/install from WG short to the Cryomodule (Installation and hook up of all the pieces from the Short to CM) (done); Cable connections to the Cryomodule and any system control or interlock checks (done); RF calibrations of cables or signals assc with preparing for CM operation not completed during RF Test in to Shorts (done)
- 181321055: Steps: Repairs and support of the RF system during CM measurements by SRF (Q, Emax, FE threshold, etc.) (done); Post CM commissioning RF system optimization and calibration prior to turn over for OPS (done)
- 281321055: Steps: RF Cavity Tests Cryomodule #10 (Install & SYS COMMIS)

| ID | WBS | Activity | Duration | Start | Finish | Predecessors | Complete | Remaining | Planned start | Planned finish | Total float | Free float | Calendar | Resources | Cost | Actual cost | MONTHLY EV COST | ReBaseline Actuals Adjustment | Original Activity ID Rebaseline | PRIOR MONTH EV COST | RESP - Responsibility | STRT%COMP for CM EVM | FNSH%COMP for CM EVM | EVMS Reporting Codes | CAM RESPONSIBLE | CR 10-028 | CR 12-028 | CR 12-029 | BOE Labor | CR 13-015 | Post Rebaseline | Temple/Lehman | CR 14-001 | CR 10-040 | CR 11-055 | CR 12-050 | BOE Expenses | Specification | Calculated Remaining Total Cost | Advance Purchase Plan > 500K | 12 GEV MAJOR PROCUREMENT CATAGORY | Activities with Steps | CR 12-018 | CR 12-032 | CR 12-040 | Claimed Material Divider | CR 11-036 | MARCH!!! | BOE NOTES | CR 07-024 | CR 09-012 | CR 09-028 | CR 09-028 Repair | CR 11-026 | CR 12-025 | BOE Adder | CR 11-038 | CR 12-024 | CR 13-002 | CR 13-010 |
| --- | --- | --- | --- | --- | --- | --- | --- | --- | --- | --- | --- | --- | --- | --- | --- | --- | --- | --- | --- | --- | --- | --- | --- | --- | --- | --- | --- | --- | --- | --- | --- | --- | --- | --- | --- | --- | --- | --- | --- | --- | --- | --- | --- | --- | --- | --- | --- | --- | --- | --- | --- | --- | --- | --- | --- | --- | --- | --- | --- | --- |
|  | 2 | **1.8.1.3.2.2 POWER SUPPLY TESTING** |  | 2013-08-30 | 2014-06-25 |  |  |  |  |  |  |  |  |  |  |  |  |  |  |  |  |  |  |  |  |  |  |  |  |  |  |  |  |  |  |  |  |  |  |  |  |  |  |  |  |  |  |  |  |  |  |  |  |  |  |  |  |  |  |  |
|  | 1 | **1.8.1.3.2.2.1 POWER SUPPLY TESTING** |  | 2013-08-30 | 2014-06-25 |  |  |  |  |  |  |  |  |  |  |  |  |  |  |  |  |  |  |  |  |  |  |  |  |  |  |  |  |  |  |  |  |  |  |  |  |  |  |  |  |  |  |  |  |  |  |  |  |  |  |  |  |  |  |  |
| 1813221000 |  | Re-Baseline Actuals Adjustment | 1d | 2013-08-30 A | 2013-08-30 A |  | 100% |  | 2013-09-03 | 2013-09-03 |  |  |  | PROCUREMENT>$50K 69 NO ESCALATION |  |  | 0 | ADJ |  |  |  |  |  |  |  |  |  |  |  |  |  |  |  |  |  |  |  |  |  |  |  |  |  |  |  |  |  |  |  |  |  |  |  |  |  |  |  |  |  |  |
| 2813221005 |  | Test Arc 1 and Hall A PS w/ Dummy Load FY13 | 16d | 2013-09-09 A | 2014-01-17 | 23221133a FS-55d, 23221133 FS-55d | 50% | 46d | 2013-10-01 | 2013-10-22 | 110d | 14d | 8/5 M-F w/JLAB Holidays ReBaseline | ELEC TECH [50.58 h]; ELEC DES [16.52 h]; ELEC ENG [10.32 h] | 4,040.58 | 1,010.55 | 0 |  | 23221135 | 1957.9415055 | MERZ B | 1 | 1 | U | BILL M | 10-028 | 12-028 | 12-029F | PE | 13-015 | PR | LR13 |  |  |  |  |  |  |  |  |  |  |  |  |  |  |  |  |  |  |  |  |  |  |  |  |  |  |  |  |
| 2813221005a |  | Test Arc 1 and Hall A PS w/ Dummy Load FY14 | 46d | 2013-09-09 A | 2014-01-17 | 2813221005 FS-60d | 50% | 46d | 2013-12-06 | 2014-02-20 | 110d | 64d | 8/5 M-F w/JLAB Holidays ReBaseline | ELEC TECH [145.42 h]; ELEC DES [47.48 h]; ELEC ENG [29.68 h] | 11,616.58 | 2,905.3 | 0 |  | 23221135 | 5808.2844255 | MERZ B | 1 | 1 | U | BILL M | 10-028 | 12-028 | 12-029F | PE | 13-015 | PR | LR13 | 14-001 |  |  |  |  |  |  |  |  |  |  |  |  |  |  |  |  |  |  |  |  |  |  |  |  |  |  |  |
| 2813221000 |  | Test Magnet System Box Power Supplies w/Dummy Load FY13 | 16d | 2013-10-01 A | 2014-06-25 | 3A-23M, 23221024ba FS-194d | 8% | 157d | 2013-11-01 | 2013-11-22 | 0d |  | 8/5 M-F w/JLAB Holidays ReBaseline | ELEC TECH [104.49 h]; ELEC ENG [52.24 h]; ELEC DES [52.24 h] | 11,644.9 | 1,487.96 | 902.835396 |  | 23221025 |  | MERZ B | 1 | 1 | U | BILL M | 10-028 |  | 12-029 | PE | 13-015 | PR | LR13 |  | 10-040 | 11-055 | 12-050 |  |  |  |  |  |  |  |  |  |  |  |  |  |  |  |  |  |  |  |  |  |  |  |  |
| 2813221000a |  | Test Magnet System Box Power Supplies w/Dummy Load FY14 | 159d | 2013-10-01 A | 2014-06-25 | 2813221000 FS-160d | 8% | 157d | 2013-11-25 | 2014-07-22 | 0d |  | 8/5 M-F w/JLAB Holidays ReBaseline | ELEC TECH [1175.51 h]; ELEC ENG [587.75 h]; ELEC DES [587.75 h] | 131,004.7 | 16,739.5 | 10480.376956 |  | 23221025 |  | MERZ B | 1 | 1 | U | BILL M | 10-028 |  | 12-029 | PE | 13-015 | PR | LR13 | 14-001 | 10-040 | 11-055 | 12-050 |  |  |  |  |  |  |  |  |  |  |  |  |  |  |  |  |  |  |  |  |  |  |  |  |
|  | 4 | **1.8.1.3.2.2.4 POWER SUPPLY INTEGRATED TESTING** |  | 2013-09-30 | 2014-05-30 |  |  |  |  |  |  |  |  |  |  |  |  |  |  |  |  |  |  |  |  |  |  |  |  |  |  |  |  |  |  |  |  |  |  |  |  |  |  |  |  |  |  |  |  |  |  |  |  |  |  |  |  |  |  |  |
| 2813224005 |  | Intergation Testing- Trim PS | 80d | 2013-09-30 A | 2014-03-07 | 23224085Aa FS-23d, 23224085A FS-23d | 10% | 80d | 2013-10-01 | 2014-02-04 | 13d | 0d | 8/5 M-F w/JLAB Holidays ReBaseline | SUPPLIES & MATERIALS; ELEC ENG [40 h]; ELEC TECH [500 h]; ELEC DES [80 h] | 32,135.65 | 368.55 | 3213.565 |  | 23224110 |  | MERZ B | 1 | 1 | U | BILL M | 10-028 | 12-028 |  | PE | 13-015 | PR | LR13 | 14-001 |  |  |  | PE |  |  |  |  |  |  |  |  |  |  |  |  |  |  |  |  |  |  |  |  |  |  |  |
| 2813224000 |  | Integration Testing- Box PS FY13 | 8d | 2013-10-01 A | 2014-05-30 | 23224055 FS-35d, 23224055a FS-35d | 4% | 139d | 2013-11-01 | 2013-11-12 | 18d | 11d | 8/5 M-F w/JLAB Holidays ReBaseline | ELEC ENG [3.76 h]; ELEC DES [7.53 h]; SUPPLIES & MATERIALS; ELEC TECH [22.59 h] | 1,862.7 | 248.33 | 82.44412551 |  | 23224105 |  | MERZ B | 1 | 1 | U | BILL M | 10-028 | 12-028 | 12-029F | PE | 13-015 | PR | LR13 |  |  |  |  | PE |  |  |  |  |  |  |  |  |  |  |  |  |  |  |  |  |  |  |  |  |  |  |  |
| 2813224000a |  | Integration Testing- Box PS FY14 | 162d | 2013-10-01 A | 2014-05-30 | 2813224000 FS-150d | 4% | 139d | 2013-11-13 | 2014-07-15 | 18d |  | 8/5 M-F w/JLAB Holidays ReBaseline | ELEC ENG [76.24 h]; ELEC DES [152.47 h]; SUPPLIES & MATERIALS; ELEC TECH [457.41 h] | 37,795.77 | 5,028.95 | 1699.72452855 |  | 23224105 |  | MERZ B | 1 | 1 | U | BILL M | 10-028 | 12-028 | 12-029F | PE | 13-015 | PR | LR13 | 14-001 |  |  |  | PE |  |  |  |  |  |  |  |  |  |  |  |  |  |  |  |  |  |  |  |  |  |  |  |
|  | 3 | **1.8.1.3.3 CRYOGENICS PRE-OPS CHECKOUT** |  | 2012-12-17 | 2013-08-30 |  |  |  |  |  |  |  |  |  |  |  |  |  |  |  |  |  |  |  |  |  |  |  |  |  |  |  |  |  |  |  |  |  |  |  |  |  |  |  |  |  |  |  |  |  |  |  |  |  |  |  |  |  |  |  |
|  | 1 | **1.8.1.3.3.1 CHL II PRE-OPS CHECKOUT** |  | 2012-12-17 | 2013-08-30 |  |  |  |  |  |  |  |  |  |  |  |  |  |  |  |  |  |  |  |  |  |  |  |  |  |  |  |  |  |  |  |  |  |  |  |  |  |  |  |  |  |  |  |  |  |  |  |  |  |  |  |  |  |  |  |
| 181331000 |  | Cmmssn CHL Helium Plant Revised | 46d | 2012-12-17 A | 2013-06-17 A | 1331.11000 FS-50d | 100% |  | 2013-03-01 | 2013-05-03 |  |  |  | MECH TECH [377.6 h]; ELEC ENG [377.6 h]; ELEC TECH [377.6 h]; MECH ENG [566.4 h]; SUPPLIES & MATERIALS | 739,252.85 | 102,990.4 | 739252.85 |  |  |  | ARENIUS D | 1 | 1 | S | DANA A |  |  | 12-029F |  |  |  |  |  |  |  |  |  | 181331000 | 0 | APP | 33111 | ST | 12-018F | 12-032 | 12-040 |  |  |  |  |  |  |  |  |  |  |  |  |  |  |  |
| 181331005 |  | Re-Baseline Actuals Adjustment | 1d | 2013-08-30 A | 2013-08-30 A |  | 100% |  | 2013-09-03 | 2013-09-03 |  |  |  | PROCUREMENT>$50K 69 NO ESCALATION | -57,741.53 |  |  | ADJ |  |  |  |  |  |  |  |  |  |  |  |  |  |  |  |  |  |  |  |  |  |  |  |  |  |  |  | 100 |  |  |  |  |  |  |  |  |  |  |  |  |  |  |
|  | 2 | **1.8.1.3.3.2 HALL D CRYOGENICS PRE-OPS CHECKOUT** |  | 2012-12-17 | 2013-08-30 |  |  |  |  |  |  |  |  |  |  |  |  |  |  |  |  |  |  |  |  |  |  |  |  |  |  |  |  |  |  |  |  |  |  |  |  |  |  |  |  |  |  |  |  |  |  |  |  |  |  |  |  |  |  |  |
| 181332000 |  | Commission Solenoid Distribution Can | 20d | 2012-12-17 A | 2013-04-15 A | 13321050 FS-15d, 13321070 | 100% |  | 2013-01-02 | 2013-01-30 |  |  |  | MECH ENG [200 h]; SR STAFF [120 h]; MECH DES [80 h]; ELEC TECH [120 h]; MECH TECH [480 h] | 59,918.4 | 59,918.4 | 59918.4 |  |  |  | ARENIUS D | 1 | 1 | H | DANA A |  |  |  |  |  |  |  |  |  |  |  |  | 181332000 | 0 |  |  |  |  |  | 12-040 |  | 11-036 | XX |  |  |  |  |  |  |  |  |  |  |  |  |
| 181332005 |  | Re-Baseline Actuals Adjustment | 1d | 2013-08-30 A | 2013-08-30 A |  | 100% |  | 2013-09-03 | 2013-09-03 |  |  |  | PROCUREMENT>$50K 69 NO ESCALATION | -11,463.38 |  |  | ADJ |  |  |  |  |  |  |  |  |  |  |  |  |  |  |  |  |  |  |  |  |  |  |  |  |  |  |  | 100 |  |  |  |  |  |  |  |  |  |  |  |  |  |  |
|  | 2 | **1.8.2 HALLS PRE-OPS** |  | 2012-10-01 | 2016-06-24 |  |  |  |  |  |  |  |  |  |  |  |  |  |  |  |  |  |  |  |  |  |  |  |  |  |  |  |  |  |  |  |  |  |  |  |  |  |  |  |  |  |  |  |  |  |  |  |  |  |  |  |  |  |  |  |
|  | 1 | **1.8.2.1 HALL A CHECKOUT AND BEAM COMMISSIONING** |  | 2014-02-26 | 2014-02-28 |  |  |  |  |  |  |  |  |  |  |  |  |  |  |  |  |  |  |  |  |  |  |  |  |  |  |  |  |  |  |  |  |  |  |  |  |  |  |  |  |  |  |  |  |  |  |  |  |  |  |  |  |  |  |  |
|  | X | **1.8.2.1.X HALL A COMMISSIONING WITH BEAM** |  | 2014-02-26 | 2014-02-28 |  |  |  |  |  |  |  |  |  |  |  |  |  |  |  |  |  |  |  |  |  |  |  |  |  |  |  |  |  |  |  |  |  |  |  |  |  |  |  |  |  |  |  |  |  |  |  |  |  |  |  |  |  |  |  |
| 2821X000 |  | H-A PRE-OPS Cmmssn with Beam | 3d | 2014-02-26 | 2014-02-28 | 3P-12M |  |  |  |  | 21d | 8d | 8/5 M-F w/JLAB Holidays ReBaseline | SCIENTIST [112 h]; VISTNG USERS [84 h]; CONTRB UNIV LBR [168 h]; MECH ENG [28 h] | 12,240.48 |  | 0 |  | 2821X000 |  | LEROSE J | 1 | 1 |  | JOHN L |  |  |  | PE | 13-015 | PR |  | 14-001 |  |  |  | PE |  | 0 |  |  |  |  |  | 12-040 |  |  |  | Re procurement, there's really nothing to buy | 07-024 | 09-012 | 09-028 | 09-028 | 11-026 | 12-025 | NO |  |  |  |  |
|  | 2 | **1.8.2.2 HALL B CHECKOUT AND BEAM COMMISSIONING** |  | 2012-12-03 | 2016-06-24 |  |  |  |  |  |  |  |  |  |  |  |  |  |  |  |  |  |  |  |  |  |  |  |  |  |  |  |  |  |  |  |  |  |  |  |  |  |  |  |  |  |  |  |  |  |  |  |  |  |  |  |  |  |  |  |
|  | X | **1.8.2.2.X HALL B COMMISSIONING WITH BEAM** |  | 2016-06-13 | 2016-06-24 |  |  |  |  |  |  |  |  |  |  |  |  |  |  |  |  |  |  |  |  |  |  |  |  |  |  |  |  |  |  |  |  |  |  |  |  |  |  |  |  |  |  |  |  |  |  |  |  |  |  |  |  |  |  |  |
| 2822X000 |  | H-B PRE-OPS Cmmssn with Beam | 10d | 2016-06-13 | 2016-06-24 | 3P-20M |  |  |  |  | -60d | 0d | 8/5 M-F w/JLAB Holidays ReBaseline | MECH ENG [168 h]; CONTRB UNIV LBR [1008 h]; VISTNG USERS [1344 h]; SCIENTIST [784 h]; MECH TECH [56 h] | 101,808.56 |  | 0 |  | 2822X000 |  | ELOUADRHIRI L | 1 | 1 | S | LATIFA E |  |  |  | PE | 13-015 | PR |  | 14-001 |  |  |  |  |  |  |  |  |  |  |  | 12-040 |  |  |  |  | 07-024 | 09-012 | 09-028 | 09-028 | 11-026 |  |  | 11-038 | 12-024 | 13-002 | 13-010 |

Notes:
- 181331000: Entry Criteria: Ext Pred: Building / BOD / Steps: Vacuum System operational (done); Controls Checkout Complete (done); Decontamination Complete (done); Turbine Installation Complete (done); 80K Cold Box Cool Down Complete (done); 4.5K Cold Box Cool Down Complete (done); Helium Dewar Operational (done); Cold Box Transfer Line Operational (done)

| ID | WBS | Activity | Duration | Start | Finish | Predecessors | Complete | Planned start | Planned finish | Total float | Free float | Calendar | Resources | Cost | Actual cost | Calculated Remaining Total Cost | MONTHLY EV COST | PHAS - Project Phase | RESP - Responsibility | STRT%COMP for CM EVM | FNSH%COMP for CM EVM | EVMS Reporting Codes | CAM RESPONSIBLE | CR 12-007 | CR 12-040 | Activities with Steps | CR 11-026 | CR 08-016 | CR 09-012 | CR 09-030 Repair | CR 12-027 | CR 12-054 | Claimed Material Divider | ReBaseline Actuals Adjustment | Original Activity ID Rebaseline | CR 13-002 | BOE Labor | CR 13-015 | Post Rebaseline | CR 14-001 | Pre Rebaseline Remaining Budget | Previously In Progress | BOE Expenses | Temple/Lehman | CR 12-052 | CR 13-010 | CR 11-035 | CR 12-024 | CR 07-024 | CR 09-028 | CR 09-028 Repair | CR 11-038 | CR 12-012 | CR 12-036 | CR 13-006 |
| --- | --- | --- | --- | --- | --- | --- | --- | --- | --- | --- | --- | --- | --- | --- | --- | --- | --- | --- | --- | --- | --- | --- | --- | --- | --- | --- | --- | --- | --- | --- | --- | --- | --- | --- | --- | --- | --- | --- | --- | --- | --- | --- | --- | --- | --- | --- | --- | --- | --- | --- | --- | --- | --- | --- | --- |
|  | 1 | **1.8.2.2.1 NOT USED** |  |  |  |  |  |  |  |  |  |  |  |  |  |  |  |  |  |  |  |  |  |  |  |  |  |  |  |  |  |  |  |  |  |  |  |  |  |  |  |  |  |  |  |  |  |  |  |  |  |  |  |  |  |
|  | 2 | **1.8.2.2.2 NOT USED** |  |  |  |  |  |  |  |  |  |  |  |  |  |  |  |  |  |  |  |  |  |  |  |  |  |  |  |  |  |  |  |  |  |  |  |  |  |  |  |  |  |  |  |  |  |  |  |  |  |  |  |  |  |
|  | 3 | **1.8.2.2.3 HALL B TRIGGER, DAQ AND ONLINE SOFTWARE CHECKOUT** |  | 2012-12-03 | 2015-10-23 |  |  |  |  |  |  |  |  |  |  |  |  |  |  |  |  |  |  |  |  |  |  |  |  |  |  |  |  |  |  |  |  |  |  |  |  |  |  |  |  |  |  |  |  |  |  |  |  |  |  |
| 18223015 |  | TI testing of 52 boards | 189d | 2012-12-03 A | 2012-12-17 A | 14231075 | 100% | 2013-01-02 | 2013-09-30 |  |  |  | SCIENTIST [121.94 h] | 8,884.55 | 8,884.55 | 0 | 7944.6544 | IN | ELOUADRHIRI L | 1 | 1 | U | LATIFA E | 12-007 | 12-040 |  |  |  |  |  |  |  |  |  |  |  |  |  |  |  |  |  |  |  |  |  |  |  |  |  |  |  |  |  |  |
| 18223020 |  | TD testing of 10 boards | 189d | 2012-12-03 A | 2012-12-17 A | 14231090 | 100% | 2013-01-02 | 2013-09-30 |  |  |  | SCIENTIST [30.48 h] | 2,220.77 | 2,220.77 | 0 | 1985.435 | IN | ELOUADRHIRI L | 1 | 1 | U | LATIFA E | 12-007 | 12-040 |  |  |  |  |  |  |  |  |  |  |  |  |  |  |  |  |  |  |  |  |  |  |  |  |  |  |  |  |  |  |
| 18223025 |  | DAQ Commissioning | 188d | 2012-12-03 A | 2013-08-30 A | 9-130M FS+60d | 100% | 2013-01-03 | 2013-09-30 |  |  |  | SCIENTIST [544.13 h] | 39,645.31 | 39,645.31 | 26619.10956 | 39645.3118 |  | ELOUADRHIRI L | 1 | 1 | S | LATIFA E | 12-007 | 12-040 | ST | 11-026 |  |  |  |  |  |  |  |  |  |  |  |  |  |  |  |  |  |  |  |  |  |  |  |  |  |  |  |  |
| 18223030 |  | CLAS12 DAQ/online software updates FY13 | 248d | 2012-12-03 A | 2013-08-30 A | 14232010 | 100% | 2013-01-02 | 2013-12-31 |  |  |  | SCIENTIST [643.55 h]; VISTNG USERS [1287.1 h]; PD UNIV STUDNT [643.55 h] | 80,256.63 | 79,651.88 | 51983.4 | 79651.874075 | IN | ELOUADRHIRI L | 1 | 1 | S | LATIFA E | 12-007 | 12-040 | ST | 11-026 | 08-016 | 09-012 | 09-030 |  |  |  |  |  |  |  |  |  |  |  |  |  |  |  |  |  |  |  |  |  |  |  |  |  |
| 18223000 |  | CTP testing of 22 boards | 149d | 2013-08-30 A | 2013-08-30 A | 9-120M, 14231007 | 100% | 2014-02-03 | 2014-09-03 |  |  |  | SCIENTIST [41.61 h] | 3,128.24 | 3,031.7 | 3501.6516 | 3031.7046 | IN | ELOUADRHIRI L | 1 | 1 | U | LATIFA E | 12-007 | 12-040 |  | 11-026 | 08-016 | 09-012 | 09-030 | 12-027 |  |  |  |  |  |  |  |  |  |  |  |  |  |  |  |  |  |  |  |  |  |  |  |  |
| 18223005 |  | SSP testing of 15 boards | 118d | 2013-08-30 A | 2013-08-30 A | 14231025 | 100% | 2013-09-03 | 2014-02-27 |  |  |  | SCIENTIST [15.8 h] | 1,181.63 | 1,151.19 | 1386.5258 | 1151.188 | IN | ELOUADRHIRI L | 1 | 1 | U | LATIFA E | 12-007 | 12-040 |  |  |  |  |  | 12-027 |  |  |  |  |  |  |  |  |  |  |  |  |  |  |  |  |  |  |  |  |  |  |  |  |
| 18223010 |  | GTP testing of 2 boards | 69d | 2013-08-30 A | 2013-08-30 A | 14231045 | 100% | 2013-10-15 | 2014-01-30 |  |  |  | SCIENTIST [7.9 h] | 593.92 | 575.59 | 810.9318 | 575.594 | IN | ELOUADRHIRI L | 1 | 1 | U | LATIFA E | 12-007 | 12-040 |  |  |  |  |  | 12-027 | 12-054 |  |  |  |  |  |  |  |  |  |  |  |  |  |  |  |  |  |  |  |  |  |  |  |
| 18223035 |  | Re-Baseline Actuals Adjustment | 1d | 2013-08-30 A | 2013-08-30 A |  | 100% | 2013-09-03 | 2013-09-03 |  |  |  | PROCUREMENT>$50K 69 NO ESCALATION | -133,985.75 |  |  |  |  |  |  |  |  |  |  |  |  |  |  |  |  |  |  | 100 | ADJ |  |  |  |  |  |  |  |  |  |  |  |  |  |  |  |  |  |  |  |  |  |
| 28223010 |  | GTP testing of 2 boards | 62d | 2014-03-06 | 2014-06-02 | 24231045 |  |  |  | 328d | 287d | 8/5 M-F w/JLAB Holidays ReBaseline | ELEC ENG [80 h]; SCIENTIST [80 h] | 12,024.8 |  |  | 0 | IN | ELOUADRHIRI L | 1 | 1 | U | LATIFA E | 12-007 | 12-040 |  |  |  |  |  | 12-027 | 12-054 |  |  | 28223010 | 13-002F | PE | 13-015 | PR | 14-001 |  |  |  |  |  |  |  |  |  |  |  |  |  |  |  |
| 28223025 |  | DAQ Commissioning | 267d | 2014-09-03 | 2015-10-01 | 9-140M FS+228d |  |  |  | 57d | 150d | 8/5 M-F w/JLAB Holidays ReBaseline | SCIENTIST [480 h] | 36,086.4 |  |  | 0 |  | ELOUADRHIRI L | 1 | 1 | S | LATIFA E | 12-007 | 12-040 |  | 11-026 |  |  |  |  |  |  |  | 28223025 | 13-002F | PE | 13-015 | PR | 14-001 | 26619.1 | Review |  |  |  |  |  |  |  |  |  |  |  |  |  |
| 28223030 |  | CLAS12 DAQ/online software updates | 267d | 2014-09-03 | 2015-10-01 | 9-140M FS+228d |  |  |  | 57d | 150d | 8/5 M-F w/JLAB Holidays ReBaseline | SCIENTIST [420.56 h]; VISTNG USERS [841.13 h]; PD UNIV STUDNT [420.56 h] | 53,714.13 |  |  | 0 | IN | ELOUADRHIRI L | 1 | 1 | S | LATIFA E | 12-007 | 12-040 |  | 11-026 | 08-016 | 09-012 | 09-030 |  |  |  |  | 28223030 | 13-002F | PE | 13-015 | PR | 14-001 | 51983.4 | Review |  |  |  |  |  |  |  |  |  |  |  |  |  |
| 28223000 |  | CTP testing of 22 boards | 64d | 2015-04-29 | 2015-07-30 | 24231007 |  |  |  | 41d | 0d | 8/5 M-F w/JLAB Holidays ReBaseline | SCIENTIST [320 h]; ELEC ENG [320 h] | 48,099.2 |  |  | 0 | IN | ELOUADRHIRI L | 1 | 1 | U | LATIFA E | 12-007 | 12-040 |  | 11-026 | 08-016 | 09-012 | 09-030 | 12-027 |  |  |  | 28223000 | 13-002F | PE | 13-015 | PR | 14-001 |  |  |  |  |  |  |  |  |  |  |  |  |  |  |  |
| 28223040 |  | Trigger system commissioning | 60d | 2015-07-31 | 2015-10-23 | 24242057, 28223000, 28223010 |  |  |  | 41d | 134d | 8/5 M-F w/JLAB Holidays ReBaseline | PLABOR; SCIENTIST [640 h] | 129,841.68 |  |  | 0 | IN | ELOUADRHIRI L | 1 | 1 | S | LATIFA E | 12-007 |  |  |  |  |  |  | 12-027 | 12-054 |  |  | 24231120 | 13-002F | PE | 13-015 | PR | 14-001 |  |  | PE | LR13 |  |  |  |  |  |  |  |  |  |  |  |
|  | 6 | **1.8.2.2.6 HALL B MAGNET INSTALLATION TESTING** |  | 2015-07-01 | 2016-02-29 |  |  |  |  |  |  |  |  |  |  |  |  |  |  |  |  |  |  |  |  |  |  |  |  |  |  |  |  |  |  |  |  |  |  |  |  |  |  |  |  |  |  |  |  |  |  |  |  |  |  |
| 28226000 |  | Commission Cryogenic System | 10d | 2015-07-01 | 2015-07-15 | 24264780 |  |  |  | 25d | 0d | 8/5 M-F w/JLAB Holidays ReBaseline | MECH ENG [80 h]; MECH TECH [80 h]; ELEC TECH [80 h] | 13,518.4 |  |  | 0 |  | ELOUADRHIRI L | 1 | 1 | S | LATIFA E |  |  |  |  |  |  |  |  |  |  |  | 24264782 | 13-002 | PE | 13-015 | PR | 14-001 |  |  |  | LR13 | 12-052 | 13-010 |  |  |  |  |  |  |  |  |  |
| 28226005 |  | Cooldown | 20d | 2015-07-16 | 2015-08-12 | 24264555, 24264780, 28226000 |  |  |  | 25d | 0d | 8/5 M-F w/JLAB Holidays ReBaseline | MECH TECH [600 h]; MECH ENG [436.8 h]; ELEC ENG [160 h] | 73,028.66 |  |  | 0 |  | ELOUADRHIRI L | 1 | 1 | S | LATIFA E |  |  |  |  |  |  |  |  |  |  |  | 24264785 | 13-002 | PE | 13-015 | PR | 14-001 |  |  |  | LR13 | 12-052 | 13-010 |  |  |  |  |  |  |  |  |  |
| 28226010 |  | Torus Operational Tests | 10d | 2015-08-13 | 2015-08-26 | 28226005 |  |  |  | 25d | 0d | 8/5 M-F w/JLAB Holidays ReBaseline | MECH TECH [276 h]; MECH ENG [219.2 h]; ELEC ENG [80 h] | 35,438.38 |  |  | 0 |  | ELOUADRHIRI L | 1 | 1 | S | LATIFA E |  |  |  |  |  |  |  |  |  |  |  | 24264787 | 13-002 | PE | 13-015 | PR | 14-001 |  |  |  | LR13 | 12-052 | 13-010 |  |  |  |  |  |  |  |  |  |
| 28226015 |  | Map CLAS12 Torus Field both polarities | 16d | 2015-08-27 | 2015-09-18 | 28226010 |  |  |  | 25d | 0d | 8/5 M-F w/JLAB Holidays ReBaseline | MECH TECH [160 h]; CONTRB UNIV LBR [160 h]; SCIENTIST [160 h] | 19,600 |  |  | 0 |  | ELOUADRHIRI L | 1 | 1 | S | LATIFA E |  |  |  |  |  |  |  |  |  |  |  | 24264788 | 13-002 | PE | 13-015 | PR | 14-001 |  |  |  | LR13 | 12-052 | 13-010 |  |  |  |  |  |  |  |  |  |
| 28226020 |  | Solenoid Cool Down | 18d | 2016-01-13 | 2016-02-08 | 24264825 |  |  |  | -93d | 0d | 8/5 M-F w/JLAB Holidays ReBaseline | MECH ENG [72 h]; MECH TECH [72 h] | 8,783.28 |  |  | 0 |  | ELOUADRHIRI L | 1 | 1 | H | LATIFA E | 12-007 |  |  |  |  |  |  |  |  |  |  | 24264830 | 13-002 | PE | 13-015 | PR | 14-001 |  |  |  | LR13 | 12-052 |  | 11 -035 | 12-024 |  |  |  |  |  |  |  |
| 28226025 |  | Solenoid Acceptance Tests and Mapping | 15d | 2016-02-09 | 2016-02-29 | 28226020 |  |  |  | -93d | 0d | 8/5 M-F w/JLAB Holidays ReBaseline | MECH TECH [48 h]; MECH ENG [48 h] | 5,855.52 |  |  | 0 |  | ELOUADRHIRI L | 1 | 1 | H | LATIFA E |  |  |  |  |  |  |  |  |  |  |  | 24264840 | 13-002 | PE | 13-015 | PR | 14-001 |  |  |  | LR13 | 12-052 | 13-010 |  |  |  |  |  |  |  |  |  |
|  | 3 | **1.8.2.3 HALL C CHECKOUT AND BEAM COMMISSIONING** |  | 2014-08-11 | 2016-02-08 |  |  |  |  |  |  |  |  |  |  |  |  |  |  |  |  |  |  |  |  |  |  |  |  |  |  |  |  |  |  |  |  |  |  |  |  |  |  |  |  |  |  |  |  |  |  |  |  |  |  |
|  | X | **1.8.2.3.X HALL C COMMISSIONG WITH BEAM** |  | 2016-02-02 | 2016-02-08 |  |  |  |  |  |  |  |  |  |  |  |  |  |  |  |  |  |  |  |  |  |  |  |  |  |  |  |  |  |  |  |  |  |  |  |  |  |  |  |  |  |  |  |  |  |  |  |  |  |  |
| 2823X000 |  | H-C PRE-OPS Cmmssn with Beam | 5d | 2016-02-02 | 2016-02-08 | 3P-18M |  |  |  | 38d | 0d | 8/5 M-F w/JLAB Holidays ReBaseline | MECH ENG [84 h]; CONTRB UNIV LBR [504 h]; MECH TECH [28 h]; VISTNG USERS [336 h]; SCIENTIST [392 h] | 43,986.04 |  |  | 0 |  | FENKER H | 1 | 1 | S | HOWARD F |  | 12-040 | ST | 11-026 |  | 09-012 |  |  | 12-054 |  |  | 2823X000 |  | PE | 13-015 | PR | 14-001 |  |  |  |  |  |  |  |  | 07-024 | 09-028 | 09-028 | 11-038 | 12-012 | 12-036 | 13-006 |

Notes:
- 18223025: Steps: Testing the DAQ configuration in beam test (done); Testing the DAQ configuration with FADC PCAL (done); Testing the DAQ configuration with FADC FTOF (done); Testing the DAQ configuration with FADC CTOF (done); Testing the DAQ configuration with FADC LTCC (done)
- 18223030: Steps: Developing online software in beam test (done); Developing online software for PCAL (done); Developing online software for FTOF (done); Developing online software for CTOF (done); Developing online software for LTCC (done)
- 2823X000: Steps: Beam in Hall-C; Power dipole w/Beam On; Record beam-correlated signals from hodoscopes; Record coincidence-triggered data

| ID | WBS | Activity | Duration | Start | Finish | Predecessors | Complete | Planned start | Planned finish | Total float | Free float | Calendar | Resources | Cost | Actual cost | Original Activity ID Rebaseline | Howard's Code | MONTHLY EV COST | RESP - Responsibility | STRT%COMP for CM EVM | FNSH%COMP for CM EVM | EVMS Reporting Codes | CAM RESPONSIBLE | CR 08-048 | Activities with Steps | CR 09-012 | CR 09-022 | CR 09-041 | CR 10-067 | CR 10-069 | CR 11-026 | CR 11-046 | CR 12-003 | CR 12-012 | CR 12-036 | CR 12-054 | CR 13-006 | BOE Labor | CR 13-015 | Post Rebaseline | Temple/Lehman | CR 14-001 | Advance Purchase Plan > 500K | CR 08-016 | 12 GEV MAJOR PROCUREMENT CATAGORY | CR 10-063 | CR 10-074 | CR 10-076 | CR 11-017 | BOE Procurement | BOE Expenses | CR 07-034 | CR 11-025 | HALL D Related Milestones | CR 07-024 | CR 09-014 | CR 09-028 | CR 09-028 Repair | CR 11-006 | CR 11-038 | CR 12-021 | CR 12-040 | CR 13-007 | Calculated Remaining Total Cost | 12 GeV 3rd level Critical Path | CR 10-042 | CR 11-004 | CR 11-036 | 12 GeV 2nd level Critical Path | MARCH!!! | Remaining Material Cost Based on % Compl | Claimed Material Cost Based on % Complet | Initial Claimed Material Calc | Claimed Material Divider | ReBaseline Actuals Adjustment | PRIOR MONTH EV COST | CR 12-034 | Obligated Prior to Rebaseline |
| --- | --- | --- | --- | --- | --- | --- | --- | --- | --- | --- | --- | --- | --- | --- | --- | --- | --- | --- | --- | --- | --- | --- | --- | --- | --- | --- | --- | --- | --- | --- | --- | --- | --- | --- | --- | --- | --- | --- | --- | --- | --- | --- | --- | --- | --- | --- | --- | --- | --- | --- | --- | --- | --- | --- | --- | --- | --- | --- | --- | --- | --- | --- | --- | --- | --- | --- | --- | --- | --- | --- | --- | --- | --- | --- | --- | --- | --- | --- |
|  | 1 | **1.8.2.3.1 HALL C HB AND Q1 TESTING** |  | 2014-08-11 | 2014-10-27 |  |  |  |  |  |  |  |  |  |  |  |  |  |  |  |  |  |  |  |  |  |  |  |  |  |  |  |  |  |  |  |  |  |  |  |  |  |  |  |  |  |  |  |  |  |  |  |  |  |  |  |  |  |  |  |  |  |  |  |  |  |  |  |  |  |  |  |  |  |  |  |  |  |
| 28231005 |  | Q1 Cooldown and Acceptance Test | 30d | 2014-08-11 | 2014-09-22 | 24312053M, 24368290, 2-27M, 24312050c FS-36d, 24368265, 24368185 |  |  |  | 250d | 0d | 8/5 M-F w/JLAB Holidays ReBaseline | MECH DES [40 h]; MECH ENG [160 h]; MECH TECH [240 h] | 25,356 |  | 24312050a | 5 | 0 | FENKER H | 1 | 1 | S | HOWARD F | 08-048 | ST | 09-012 | 09-022 | 09-041 | 10-067 | 10-069 | 11-026 | 11-046 | 12-003 | 12-012 | 12-036 | 12-054 | 13-006 | PE | 13-015 | PR | LR13 | 14-001 |  |  |  |  |  |  |  |  |  |  |  |  |  |  |  |  |  |  |  |  |  |  |  |  |  |  |  |  |  |  |  |  |  |  |  |  |
| 28231010 |  | Q1 Harmonic Coil Test | 5d | 2014-09-23 | 2014-09-29 | 28231005, 24353015 |  |  |  | 270d | 0d | 8/5 M-F w/JLAB Holidays ReBaseline | MECH TECH [20 h]; MECH ENG [40 h] | 3,933.2 |  | 24312050b | 5 | 0 | FENKER H | 1 | 1 | H | HOWARD F |  |  |  |  | 09-041 | 10-067 | 10-069 | 11-026 | 11-046 | 12-003 | 12-012 | 12-036 | 12-054 | 13-006 | PE | 13-015 | PR | LR13 | 14-001 |  |  |  |  |  |  |  |  |  |  |  |  |  |  |  |  |  |  |  |  |  |  |  |  |  |  |  |  |  |  |  |  |  |  |  |  |
| 28231000 |  | HB-Acceptance Test | 20d | 2014-09-30 | 2014-10-27 | 24368295, 24368265, 2-28M |  |  |  | 250d | 0d | 8/5 M-F w/JLAB Holidays ReBaseline | MECH DES [40 h]; MECH ENG [160 h]; MECH TECH [240 h] | 25,356 |  | 24311066 | 5 | 0 | FENKER H | 1 | 1 | S | HOWARD F | 08-048 | ST | 09-012 | 09-022 |  |  | 10-069 | 11-026 | 11-046 |  | 12-012 | 12-036 |  | 13-006 | PE | 13-015 | PR | LR13 | 14-001 | APP | 08-016 | 4311 | 10-063 | 10-074 |  |  |  |  |  |  |  |  |  |  |  |  |  |  |  |  |  |  |  |  |  |  |  |  |  |  |  |  |  |  |  |
|  | 6 | **1.8.2.3.6 HALL C DIPOLE AND Q2Q3 MAGNET TESTING** |  | 2015-07-02 | 2015-12-23 |  |  |  |  |  |  |  |  |  |  |  |  |  |  |  |  |  |  |  |  |  |  |  |  |  |  |  |  |  |  |  |  |  |  |  |  |  |  |  |  |  |  |  |  |  |  |  |  |  |  |  |  |  |  |  |  |  |  |  |  |  |  |  |  |  |  |  |  |  |  |  |  |  |
| 28236000 |  | Cool Down Dipole Magnet | 25d | 2015-07-02 | 2015-08-06 | 24368305, 24368265, 24368310, 24368315, 24368185 |  |  |  | 0d |  | 8/5 M-F w/JLAB Holidays ReBaseline | MECH TECH [100 h]; MECH DES [100 h]; MECH ENG [40 h] | 12,848.8 |  | 24368077 | 5 | 0 | FENKER H | 1 | 1 | S | HOWARD F |  | ST |  | 09-022 |  |  | 10-069 | 11-026 | 11-046 |  | 12-012 | 12-036 | 12-054 | 13-006 | PE | 13-015 | PR | LR13 | 14-001 | APP |  |  |  |  | 10-076 | 11-017 | EJ | EJ |  |  |  |  |  |  |  |  |  |  |  |  |  |  |  |  |  |  |  |  |  |  |  |  |  |  |  |
| 28236010 |  | Q2 Cooldown and Acceptance Test | 30d | 2015-07-23 | 2015-09-02 | 24368265, 24368340, 24368185, 24315037b, 24368325 |  |  |  | 0d |  | 8/5 M-F w/JLAB Holidays ReBaseline | MECH DES [40 h]; MECH ENG [160 h]; MECH TECH [240 h] | 25,356 |  | 24368495 | 5 | 0 | FENKER H | 1 | 1 | S | HOWARD F | 08-048 | ST | 09-012 | 09-022 |  |  | 10-069 | 11-026 | 11-046 |  | 12-012 | 12-036 |  | 13-006 | PE | 13-015 | PR | LR13 | 14-001 |  |  | 4313 |  |  |  | 11-017 | PE |  | 07-034 |  |  |  |  |  |  |  |  |  |  |  |  |  |  |  |  |  |  |  |  |  |  |  |  |  |  |
| 28236005 |  | Dipole Acceptance Test | 18d | 2015-08-07 | 2015-09-01 | 28236000 |  |  |  | 0d |  | 8/5 M-F w/JLAB Holidays ReBaseline | MECH TECH [80 h]; MECH ENG [80 h] | 9,759.2 |  | 24368080 | 5 | 0 | FENKER H | 1 | 1 | H | HOWARD F |  |  |  | 09-022 |  |  | 10-069 | 11-026 | 11-046 |  | 12-012 | 12-036 | 12-054 | 13-006 | PE | 13-015 | PR | LR13 | 14-001 |  |  |  |  |  |  |  | EV |  |  | 11-025 |  |  |  |  |  |  |  |  |  |  |  |  |  |  |  |  |  |  |  |  |  |  |  |  |  |
| 28236015 |  | Q2 HC & FF Test | 5d | 2015-08-27 | 2015-09-02 | 28236010 FS-5d |  |  |  | 42d | 0d | 8/5 M-F w/JLAB Holidays ReBaseline | MECH ENG [80 h]; MECH TECH [56 h] | 8,623.52 |  | 24368490 | 5 | 0 | FENKER H | 1 | 1 | H | HOWARD F | 08-048 |  | 09-012 | 09-022 |  |  | 10-069 | 11-026 | 11-046 |  | 12-012 | 12-036 |  | 13-006 | PE | 13-015 | PR | LR13 | 14-001 |  |  | 4313 |  |  |  | 11-017 | EJ |  | 07-034 |  |  |  |  |  |  |  |  |  |  |  |  |  |  |  |  |  |  |  |  |  |  |  |  |  |  |
| 28236020 |  | Q3 Cooldown and Acceptance Test | 37d | 2015-09-11 | 2015-11-02 | 24368370, 24368265, 24368185, 24368360, 24315037b |  |  |  | 0d |  | 8/5 M-F w/JLAB Holidays ReBaseline | MECH DES [40 h]; MECH ENG [160 h]; MECH TECH [240 h] | 25,356 |  | 24368505 | 5 | 0 | FENKER H | 1 | 1 | S | HOWARD F | 08-048 | ST | 09-012 | 09-022 |  |  | 10-069 | 11-026 | 11-046 |  | 12-012 | 12-036 |  | 13-006 | PE | 13-015 | PR | LR13 | 14-001 |  |  |  |  |  |  | 11-017 |  | EJ | 07-034 |  |  |  |  |  |  |  |  |  |  |  |  |  |  |  |  |  |  |  |  |  |  |  |  |  |  |
| 28236025 |  | Q3- HC & FF Test | 5d | 2015-10-27 | 2015-11-02 | 243161015 FS-5d, 28236020 FS-5d |  |  |  | 0d |  | 8/5 M-F w/JLAB Holidays ReBaseline | MECH TECH [56 h]; MECH ENG [80 h] | 8,623.52 |  | 24368500 | 5 | 0 | FENKER H | 1 | 1 | H | HOWARD F | 08-048 |  |  | 09-022 |  |  | 10-069 | 11-026 | 11-046 |  | 12-012 | 12-036 |  | 13-006 | PE | 13-015 | PR | LR13 | 14-001 |  |  |  |  |  |  | 11-017 | PE |  | 07-034 |  |  |  |  |  |  |  |  |  |  |  |  |  |  |  |  |  |  |  |  |  |  |  |  |  |  |
| 28236030 |  | Power all Magnets together | 35d | 2015-11-03 | 2015-12-23 | 24368365, 28236025, 24368280, 28231000, 24368300, 24312051M, 28231010, 24368335M, 28236015, 24368390, 28236010 |  |  |  | 0d |  | 8/5 M-F w/JLAB Holidays ReBaseline | ELEC ENG [80 h]; MECH ENG [80 h]; MECH TECH [240 h] | 23,340.8 |  | 24368155 | 5 | 0 | FENKER H | 1 | 1 | S | HOWARD F |  | ST |  | 09-022 |  |  | 10-069 | 11-026 | 11-046 |  | 12-012 | 12-036 |  | 13-006 | PE | 13-015 | PR | LR13 | 14-001 |  |  |  |  |  |  | 11-017 |  |  |  |  |  |  |  |  |  |  |  |  |  |  |  |  |  |  |  |  |  |  |  |  |  |  |  |  |  |
|  | 4 | **1.8.2.4 HALL D CHECKOUT AND BEAM COMMISSIONING** |  | 2012-10-01 | 2014-12-11 |  |  |  |  |  |  |  |  |  |  |  |  |  |  |  |  |  |  |  |  |  |  |  |  |  |  |  |  |  |  |  |  |  |  |  |  |  |  |  |  |  |  |  |  |  |  |  |  |  |  |  |  |  |  |  |  |  |  |  |  |  |  |  |  |  |  |  |  |  |  |  |  |  |
|  | X | **1.8.2.4.X HALL D COMMISSIONING WITH BEAM** |  | 2014-11-19 | 2014-12-11 |  |  |  |  |  |  |  |  |  |  |  |  |  |  |  |  |  |  |  |  |  |  |  |  |  |  |  |  |  |  |  |  |  |  |  |  |  |  |  |  |  |  |  |  |  |  |  |  |  |  |  |  |  |  |  |  |  |  |  |  |  |  |  |  |  |  |  |  |  |  |  |  |  |
| 2824X000 |  | H-D PRE-OPS Cmmssn with Beam | 15d | 2014-11-19 | 2014-12-11 | 3P-16M |  |  |  | 8d | 0d | 8/5 M-F w/JLAB Holidays ReBaseline | SCIENTIST [1440 h]; MECH ENG [270 h]; CONTRB UNIV LBR [1440 h]; MECH TECH [160 h]; VISTNG USERS [960 h] | 155,757.7 |  | 2824X000 |  | 0 | CHUDAKOV | 1 | 1 |  | EUGENE C |  |  | 09-012 |  |  |  |  | 11-026 |  |  |  |  |  |  | PE | 13-015 | PR |  | 14-001 |  |  |  |  |  |  |  |  |  |  |  | D | 07-024 | 09-014 | 09-028 | 09-028 | 11-006 | 11-038 | 12-021 | 12-040 | 13-007 |  |  |  |  |  |  |  |  |  |  |  |  |  |  |  |
|  | 1 | **1.8.2.4.1 HALL D SOLENOID COMMISSIONING** |  | 2012-10-01 | 2014-12-08 |  |  |  |  |  |  |  |  |  |  |  |  |  |  |  |  |  |  |  |  |  |  |  |  |  |  |  |  |  |  |  |  |  |  |  |  |  |  |  |  |  |  |  |  |  |  |  |  |  |  |  |  |  |  |  |  |  |  |  |  |  |  |  |  |  |  |  |  |  |  |  |  |  |
| 18241000 |  | Install cryo/magnet elect/pipe interface | 58d | 2012-10-01 A | 2012-12-17 A | 151173a, 151173aa FS-60d, 9-130M | 100% | 2012-10-01 | 2012-12-21 |  |  |  | MECH TECH [544 h] | 24,947.84 | 24,947.84 |  |  | 24947.84 | CHUDAKOV | 1 | 1 | H | EUGENE C |  |  |  |  |  |  |  |  |  |  |  |  |  |  |  |  |  |  |  |  |  |  |  |  |  |  |  |  |  |  | D |  |  |  |  |  |  | 12-021 | 12-040 |  | 0 | 3 |  |  |  |  |  |  |  |  |  |  |  |  |  |
| 18241005 |  | Prepare for Solenoid Readiness review | 31d | 2012-10-01 A | 2012-11-12 A | 9-130M FS+9d | 100% |  |  |  |  |  | MECH ENG [119.2 h] | 8,625.31 | 8,625.31 |  |  | 8625.312 | CHUDAKOV | 1 | 1 | H | EUGENE C |  |  |  |  |  |  |  |  |  |  |  |  |  |  |  |  |  |  |  |  |  |  |  |  |  |  |  |  |  |  | D |  |  |  |  |  |  | 12-021 | 12-040 |  | 0 | 3 |  |  |  |  |  |  |  |  |  |  |  |  |  |
| 18241010 |  | Cooldown Controls Test (SOLENOID) | 36d | 2012-11-12 A | 2012-12-16 A | 151080, 151185 FS-15d | 100% | 2012-11-12 | 2013-01-10 |  |  |  | MECH TECH [305 h]; MECH ENG [305 h]; MECH DES [305 h]; SCIENTIST [305 h] | 73,440.95 | 73,440.95 |  |  | 73440.95 | CHUDAKOV | 1 | 1 | H | EUGENE C |  |  |  |  |  |  |  |  |  |  |  |  | 12-054 |  |  |  |  |  |  |  |  |  |  |  |  |  |  |  |  |  | D | 07-024 | 09-014 |  |  | 11-006 |  |  | 12-040 |  | 0 | 3 | 10-042 | 11-004 | 11-036 |  |  |  |  |  |  |  |  |  |  |
| 18241015 |  | Cooldown to 100 K (SOLENOID) | 13d | 2012-12-08 A | 2013-01-21 A | 3P-24M | 100% | 2013-01-08 | 2013-01-25 |  |  |  | MECH ENG [20 h]; MECH TECH [160 h] | 8,784.8 | 8,784.8 |  |  | 8784.8 | CHUDAKOV | 1 | 1 | H | EUGENE C |  |  |  |  |  |  |  |  |  |  |  |  |  |  |  |  |  |  |  |  |  |  |  |  |  |  |  |  |  |  | D | 07-024 | 09-014 |  |  |  |  |  | 12-040 |  | 0 |  | 10-042 | 11-004 | 11-036 | 2 | XX |  |  |  |  |  |  |  |  |
| 18241035 |  | Controls Test Solenoid (SOLENOID) | 12d | 2013-01-14 A | 2013-05-13 A | 18241030 FS-40d | 100% | 2013-03-25 | 2013-04-09 |  |  |  | SCIENTIST [960 h]; PROCUREMENT<$50K 60; MECH TECH [480 h]; MECH ENG [480 h] | 127,898.53 | 126,691.2 |  |  | 127898.53 | CHUDAKOV | 1 | 1 | S | EUGENE C |  | ST |  |  |  |  |  |  |  |  |  |  |  |  |  |  |  |  |  |  |  |  |  |  |  |  |  |  |  |  | D | 07-024 | 09-014 |  |  | 11-006 |  |  | 12-040 |  | 0 |  | 10-042 | 11-004 | 11-036 | 2 |  | 0 | 1207.33 | 120733 | 100 |  |  |  |  |
| 18241020 |  | Cooldown to 4 K (SOLENOID) | 7d | 2013-03-04 A | 2013-04-15 A | 18241015 | 100% | 2013-04-01 | 2013-04-09 |  |  |  | MECH TECH [40 h]; MECH ENG [8 h] | 2,413.28 | 2,413.28 |  |  | 2413.28 | CHUDAKOV | 1 | 1 | H | EUGENE C |  |  |  |  |  |  |  |  |  |  |  |  |  |  |  |  |  |  |  |  |  |  |  |  |  |  |  |  |  |  | D | 07-024 | 09-014 |  |  |  |  |  | 12-040 |  | 0 |  | 10-042 | 11-004 | 11-036 | 2 | XX |  |  |  |  |  |  |  |  |
| 18241025 |  | Fill with LHE (SOLENOID) | 7d | 2013-04-13 A | 2013-04-21 A | 18241020 FS+1d | 100% | 2013-05-13 | 2013-05-21 |  |  |  | MECH ENG [8 h]; MECH TECH [40 h] | 2,413.28 | 2,413.28 |  |  | 2413.28 | CHUDAKOV | 1 | 1 | H | EUGENE C |  |  |  |  |  |  |  |  |  |  |  |  |  |  |  |  |  |  |  |  |  |  |  |  |  |  |  |  |  |  | D | 07-024 | 09-014 |  |  |  |  |  | 12-040 |  | 0 |  | 10-042 | 11-004 | 11-036 | 2 | XX |  |  |  |  |  |  |  |  |
| 18241040 |  | Pwr Test Solenoid (SOLENOID) | 16d | 2013-04-15 A | 2013-08-22 A | 18241035 FS-20d | 100% | 2013-05-24 | 2013-06-17 |  |  |  | MECH TECH [480 h]; MECH ENG [480 h]; PROCUREMENT<$50K 60 | 57,952.93 | 56,745.6 |  |  | 57952.93 | CHUDAKOV | 1 | 1 | H | EUGENE C |  |  |  |  |  |  |  |  |  |  |  |  |  |  |  |  |  |  |  |  |  |  |  |  |  |  |  |  |  |  | D | 07-024 | 09-014 |  |  |  |  |  | 12-040 |  | 28976.465 |  | 10-042 | 11-004 | 11-036 | 2 |  | 0 | 1207.33 | 120733 | 100 |  |  |  |  |
| 18241030 |  | Static Test Coils (SOLENOID) | 7d | 2013-04-22 A | 2013-04-29 A | 18241025 | 100% | 2013-05-22 | 2013-05-31 |  |  |  | MECH ENG [40 h]; MECH TECH [80 h]; PROCUREMENT<$50K 60 | 7,770.53 | 6,563.2 |  |  | 7770.53 | CHUDAKOV | 1 | 1 | H | EUGENE C |  |  |  |  |  |  |  |  |  |  |  |  |  |  |  |  |  |  |  |  |  |  |  |  |  |  |  |  |  |  | D | 07-024 | 09-014 |  |  |  |  |  | 12-040 |  | 0 |  | 10-042 | 11-004 | 11-036 | 2 | XX | 0 | 1207.33 | 120733 | 100 |  |  |  |  |
| 18241050 |  | Re-Baseline Actuals Adjustment | 1d | 2013-08-30 A | 2013-08-30 A |  | 100% | 2013-09-03 | 2013-09-03 |  |  |  | PROCUREMENT>$50K 69 NO ESCALATION | 31,366.69 |  |  |  | 31366.69 |  |  |  |  |  |  |  |  |  |  |  |  |  |  |  |  |  |  |  |  |  |  |  |  |  |  |  |  |  |  |  |  |  |  |  |  |  |  |  |  |  |  |  |  |  |  |  |  |  |  |  |  | 0 | 31366.69 | 3136669 | 100 | ADJ |  |  |  |
| 25213030 |  | Consultant Fee (Quench Study WS) | 20d | 2013-09-03 A | 2013-09-23 A | 9-130M FS+228d | 100% | 2013-10-01 | 2013-10-28 |  |  | 8/5 M-F w/JLAB Holidays ReBaseline | PROCUREMENT<$50K 60 | 600 |  | 25213005 |  | 0 | CHUDAKOV | 1 | 1 | D | EUGENE C |  |  |  |  |  |  |  | 11-026 |  |  |  |  | 12-054 |  |  | 13-015 | PR |  |  |  | 08-016 |  |  |  |  |  | VQ |  |  |  | D |  | 09-014 |  |  | 11-006 |  | 12-021 |  | 13-007F |  |  |  |  |  |  |  | 0 | 600 | 60000 | 100 |  | 600 | 12-034 | OB |
| 28241000 |  | Maintanence Support Solenoid | 20d | 2013-11-01 | 2013-12-02 | 251250M FS-20d, 9-130M FS+228d |  |  |  | 11d | 0d | 8/5 M-F w/JLAB Holidays ReBaseline | MECH ENG [11.81 h]; MECH TECH [32.47 h]; SUPPLIES & MATERIALS | 3,613.85 |  | 251220 |  | 0 | CHUDAKOV | 1 | 1 | S | EUGENE C |  |  |  |  |  |  |  |  |  |  |  |  |  |  | EJ | 13-015 | PR |  |  |  |  |  |  |  |  |  |  | EJ |  |  | D | 07-024 | 09-014 |  |  |  |  |  | 12-040 | 13-007 |  |  | 10-042 | 11-004 | 11-036 | 2 |  |  |  |  |  |  |  |  |  |
| 28241000a |  | Maintanence Support Solenoid FY14 | 251d | 2013-12-03 | 2014-12-08 | 28241000 |  |  |  | 11d | 3d | 8/5 M-F w/JLAB Holidays ReBaseline | MECH ENG [148.19 h]; MECH TECH [407.53 h]; SUPPLIES & MATERIALS | 45,832.79 |  | 251220 |  | 0 | CHUDAKOV | 1 | 1 | S | EUGENE C |  |  |  |  |  |  |  |  |  |  |  |  |  |  | EJ | 13-015 | PR |  | 14-001 |  |  |  |  |  |  |  |  | EJ |  |  | D | 07-024 | 09-014 |  |  |  |  |  | 12-040 | 13-007 |  |  | 10-042 | 11-004 | 11-036 | 2 |  |  |  |  |  |  |  |  |  |

Notes:
- 28231005: Steps: Connect Magnet Utilities (cryo, DC pwr, controls); Cool-down magnet. Low-current test. Interlocks tested.; Quench & Full-current test; Magnetic Field Measurement completed
- 28231000: Steps: Connect Magnet Utilities (cryo, DC pwr, controls); Cool-down magnet. Low-current test. Interlocks tested.; Quench & Full-current test; Mapping completed
- 28236000: Steps: Connect Magnet Utilities (cryo, DC pwr, controls); Magnet cooled-down to operating temperature
- 28236010: Steps: Connect Magnet Utilities (cryo, DC pwr, controls); Cool-down magnet. Low-current test. Interlocks tested.; Q2 Full-field and Harmonic Coil Test is 28236015
- 28236005: Caution: Danger !!! PB needs 15 week duration for this / task.
- 28236020: Steps: Connect Magnet Utilities (cryo, DC pwr, controls); Cool-down magnet. Low-current test. Interlocks tested.; Q3 Full-field and Harmonic Coil Test is 28236025
- 28236030: Steps: Magnet control from Counting House Fully Functional; HB & Q1 Powered to >25% Full-field Simultaneously; Q1 & Q2 Powered to >25% Full-field Simultaneously; Q2 & Q3 Powered to >25% Full-field Simultaneously; Q3 & Dipole Powered to >25% Full-field Simultaneously; All Five Magnets Powered to >25% Full-field Simultaneously
- 18241035: Steps: Check Helium Circuit (done); 10 amp Power Test (done); Interlocks (done); Initial Ramp (done); Final Ramp (done); Dump Circuit (done)

| ID | WBS | Activity | Duration | Start | Finish | Predecessors | Complete | Planned start | Planned finish | Total float | Calendar | Resources | Cost | Actual cost | Calculated Remaining Total Cost | MONTHLY EV COST | RESP - Responsibility | STRT%COMP for CM EVM | FNSH%COMP for CM EVM | HALL D Related Milestones | EVMS Reporting Codes | CAM RESPONSIBLE | Activities with Steps | CR 10-042 | CR 11-006 | CR 11-026 | CR 12-021 | CR 12-040 | CR 12-054 | Claimed Material Divider | ReBaseline Actuals Adjustment | Original Activity ID Rebaseline | CR 13-007 | BOE Labor | CR 13-015 | Post Rebaseline | CR 14-001 |
| --- | --- | --- | --- | --- | --- | --- | --- | --- | --- | --- | --- | --- | --- | --- | --- | --- | --- | --- | --- | --- | --- | --- | --- | --- | --- | --- | --- | --- | --- | --- | --- | --- | --- | --- | --- | --- | --- |
|  | 3 | **1.8.2.4.3 HALL D ONLINE CHECKOUT** |  | 2013-07-01 | 2014-09-30 |  |  |  |  |  |  |  |  |  |  |  |  |  |  |  |  |  |  |  |  |  |  |  |  |  |  |  |  |  |  |  |  |
|  | 1 | **1.8.2.4.3.1 HALL D DAQ CHECKOUT** |  | 2013-08-30 | 2013-08-30 |  |  |  |  |  |  |  |  |  |  |  |  |  |  |  |  |  |  |  |  |  |  |  |  |  |  |  |  |  |  |  |  |
| 182431000 |  | Check-out Counting House & Equip (DAQ) | 42d | 2013-08-30 A | 2013-08-30 A | 1531110 FS-21d | 100% | 2014-01-07 | 2014-03-07 |  |  | COMP SCIENT [320 h]; SCIENTIST [120 h] | 31,380 | 30,410.4 | 30410.4 | 30410.4 | CHUDAKOV | 1 | 1 | D | S | EUGENE C | ST | 10-042 | 11-006 | 11-026 | 12-021 | 12-040 | 12-054 |  |  |  |  |  |  |  |  |
| 182431010 |  | Check-out DAQ Electrnc's (DAQ) | 84d | 2013-08-30 A | 2013-08-30 A | 1531110 | 100% | 2014-02-06 | 2014-06-05 |  |  | SCIENTIST [308.57 h] | 23,198.29 | 22,482.41 | 26229.6 | 22482.4102 | CHUDAKOV | 1 | 1 | D | S | EUGENE C | ST | 10-042 | 11-006 | 11-026 | 12-021 | 12-040 | 12-054 |  |  |  |  |  |  |  |  |
| 182431015 |  | Re-Baseline Actuals Adjustment | 1d | 2013-08-30 A | 2013-08-30 A |  | 100% | 2013-09-03 | 2013-09-03 |  |  | PROCUREMENT>$50K 69 NO ESCALATION | -52,892.81 |  |  |  |  |  |  |  |  |  |  |  |  |  |  |  |  | 100 | ADJ |  |  |  |  |  |  |
|  | 2 | **1.8.2.4.3.2 HALL D SOFTWARE CHECKOUT** |  | 2013-07-01 | 2014-09-30 |  |  |  |  |  |  |  |  |  |  |  |  |  |  |  |  |  |  |  |  |  |  |  |  |  |  |  |  |  |  |  |  |
| 182432080 |  | Check-out Experiment Control Software DAQ Interface | 10d | 2013-07-01 A | 2013-07-15 A | 1532105na | 100% | 2014-03-05 | 2014-03-18 |  |  | SCIENTIST [45.09 h] | 3,389.87 | 3,285.26 | 3285.2574 | 2861.2122 | CHUDAKOV | 1 | 1 | D | S | EUGENE C | ST |  | 11-006 | 11-026 | 12-021 | 12-040 |  |  |  |  |  |  |  |  |  |
| 182432000 |  | Check-out Front-End Software | 110d | 2013-08-30 A | 2013-08-30 A | 1532070 FS-100d | 100% | 2013-12-06 | 2014-05-20 |  |  | SCIENTIST [223.42 h] | 16,796.72 | 16,278.38 | 18821.9238 | 16278.3812 | CHUDAKOV | 1 | 1 | D | S | EUGENE C | ST |  | 11-006 | 11-026 | 12-021 | 12-040 |  |  |  |  |  |  |  |  |  |
| 182432005 |  | Check-out Monitoring | 42d | 2013-08-30 A | 2013-08-30 A | 1532082 FS-140d, 1532080c FS-100d, 1532080f FS-200d, 1532080da FS-200d, 1532080a FS-190d, 1532080g FS-220d, 1532080ba FS-200d, 1532080 | 100% | 2014-03-14 | 2014-05-12 |  |  | SCIENTIST [109.84 h] | 8,257.77 | 8,002.94 | 15278.742 | 8002.9424 | CHUDAKOV | 1 | 1 | D | S | EUGENE C | ST |  | 11-006 | 11-026 | 12-021 | 12-040 | 12-054 |  |  |  |  |  |  |  |  |
| 182432010 |  | Check-out Alarm Sys | 53d | 2013-08-30 A | 2013-08-30 A | 1532085 FS-20d | 100% | 2014-01-13 | 2014-03-28 |  |  | SCIENTIST [81.23 h] | 6,106.87 | 5,918.42 | 9505.3156 | 5918.4178 | CHUDAKOV | 1 | 1 | D | S | EUGENE C | ST |  | 11-006 | 11-026 | 12-021 | 12-040 | 12-054 |  |  |  |  |  |  |  |  |
| 182432015 |  | Check-out Archiving Sys | 122d | 2013-08-30 A | 2013-08-30 A | 1532090a FS-100d, 1532090b FS-100d, 1532090 FS-60d | 100% | 2013-10-09 | 2014-04-10 |  |  | SCIENTIST [178.04 h] | 13,385.05 | 12,971.99 | 15515.537 | 12971.9944 | CHUDAKOV | 1 | 1 | D | S | EUGENE C | ST |  | 11-006 | 11-026 | 12-021 | 12-040 |  |  |  |  |  |  |  |  |  |
| 182432020 |  | Check-out Event Displays | 10d | 2013-08-30 A | 2013-08-30 A | 1532095a | 100% | 2014-07-24 | 2014-08-06 |  |  | SCIENTIST [120.43 h]; CONTRB UNIV LBR [125.46 h] | 9,054.22 | 8,774.82 | 10046.6654 | 8774.81818 | CHUDAKOV | 1 | 1 | D | S | EUGENE C | ST |  | 11-006 | 11-026 | 12-021 | 12-040 |  |  |  |  |  |  |  |  |  |
| 182432025 |  | Check-out Storage Mngmnt Software | 122d | 2013-08-30 A | 2013-08-30 A | 1532100 FS-100d | 100% | 2014-02-03 | 2014-07-25 |  |  | SCIENTIST [59.34 h]; COMP SCIENT [103.86 h] | 11,717.9 | 11,355.89 | 13582.539 | 11355.89326 | CHUDAKOV | 1 | 1 | D | S | EUGENE C | ST |  | 11-006 | 11-026 | 12-021 | 12-040 |  |  |  |  |  |  |  |  |  |
| 182432030 |  | Check-out Experiment Control Software Framework | 10d | 2013-08-30 A | 2013-08-30 A | 1531227a, 1531150 FS-20d, 1531225, 1532105s, 1531227, 1531195, 1531165 | 100% | 2014-04-15 | 2014-04-28 |  |  | SCIENTIST [62.25 h] | 4,679.96 | 4,535.54 | 5383.6254 | 4535.535 | CHUDAKOV | 1 | 1 | D | S | EUGENE C | ST |  | 11-006 | 11-026 | 12-021 | 12-040 |  |  |  |  |  |  |  |  |  |
| 182432035 |  | Check-out Experiment Control Software Display Manegement | 10d | 2013-08-30 A | 2013-08-30 A | 1532105a | 100% | 2014-07-08 | 2014-07-21 |  |  | SCIENTIST [56.43 h] | 4,242.41 | 4,111.49 | 4959.5802 | 4111.4898 | CHUDAKOV | 1 | 1 | D | S | EUGENE C | ST |  | 11-006 | 11-026 | 12-021 | 12-040 |  |  |  |  |  |  |  |  |  |
| 182432040 |  | Check-out Experiment Control Software Backup/Restore | 50d | 2013-08-30 A | 2013-08-30 A | 1532105b FS-40d | 100% | 2013-10-17 | 2014-01-06 |  |  | SCIENTIST [61.09 h] | 4,592.75 | 4,451.02 | 5299.1078 | 4451.0174 | CHUDAKOV | 1 | 1 | D | S | EUGENE C | ST |  | 11-006 | 11-026 | 12-021 | 12-040 |  |  |  |  |  |  |  |  |  |
| 182432045 |  | Check-out Experiment Control Software Magnet PS | 110d | 2013-08-30 A | 2013-08-30 A | 1532105c FS-100d | 100% | 2013-12-12 | 2014-05-27 |  |  | SCIENTIST [59.34 h] | 4,461.18 | 4,323.51 | 5171.6028 | 4323.5124 | CHUDAKOV | 1 | 1 | D | S | EUGENE C | ST |  | 11-006 | 11-026 | 12-021 | 12-040 |  |  |  |  |  |  |  |  |  |
| 182432050 |  | Check-out Experiment Control Software HV | 10d | 2013-08-30 A | 2013-08-30 A | 1532105da | 100% | 2014-04-23 | 2014-05-06 |  |  | SCIENTIST [87.85 h] | 6,604.56 | 6,400.75 | 7248.8414 | 6400.751 | CHUDAKOV | 1 | 1 | D | S | EUGENE C | ST |  | 11-006 | 11-026 | 12-021 | 12-040 |  |  |  |  |  |  |  |  |  |
| 182432055 |  | Check-out Experiment Control Software LV | 10d | 2013-08-30 A | 2013-08-30 A | 1532105fa | 100% | 2014-04-23 | 2014-05-06 |  |  | SCIENTIST [65.89 h] | 4,953.61 | 4,800.75 | 5436.8132 | 4800.7454 | CHUDAKOV | 1 | 1 | D | S | EUGENE C | ST |  | 11-006 | 11-026 | 12-021 | 12-040 |  |  |  |  |  |  |  |  |  |
| 182432060 |  | Check-out Experiment Control Software Motors | 82d | 2013-08-30 A | 2013-08-30 A | 1532105ga | 100% | 2014-01-08 | 2014-05-05 |  |  | SCIENTIST [78.54 h] | 5,904.64 | 5,722.42 | 6570.5148 | 5722.4244 | CHUDAKOV | 1 | 1 | D | S | EUGENE C | ST |  | 11-006 | 11-026 | 12-021 | 12-040 |  |  |  |  |  |  |  |  |  |
| 182432065 |  | Check-out Experiment Control Software Gas Systems | 110d | 2013-08-30 A | 2013-08-30 A | 1532105h FS-100d | 100% | 2014-02-03 | 2014-07-09 |  |  | SCIENTIST [44.51 h] | 3,346.26 | 3,243 | 3879.0664 | 3242.9986 | CHUDAKOV | 1 | 1 | D | S | EUGENE C | ST |  | 11-006 | 11-026 | 12-021 | 12-040 |  |  |  |  |  |  |  |  |  |
| 182432070 |  | Check-out Experiment Control Software Temperature | 110d | 2013-08-30 A | 2013-08-30 A | 1532105j FS-100d | 100% | 2014-02-03 | 2014-07-09 |  |  | SCIENTIST [59.34 h] | 4,461.18 | 4,323.51 | 5171.6028 | 4323.5124 | CHUDAKOV | 1 | 1 | D | S | EUGENE C | ST |  | 11-006 | 11-026 | 12-021 | 12-040 |  |  |  |  |  |  |  |  |  |
| 182432075 |  | Check-out Experiment Control Software Target | 110d | 2013-08-30 A | 2013-08-30 A | 1532105k FS-100d | 100% | 2014-02-04 | 2014-07-10 |  |  | SCIENTIST [70.98 h] | 5,336.28 | 5,171.6 | 6019.6932 | 5171.6028 | CHUDAKOV | 1 | 1 | D | S | EUGENE C | ST |  | 11-006 | 11-026 | 12-021 | 12-040 |  |  |  |  |  |  |  |  |  |
| 182432085 |  | Level 1 Trigger Expert Software | 121d | 2013-08-30 A | 2013-08-30 A |  | 100% | 2013-09-03 | 2014-03-04 |  |  | SCIENTIST [146.91 h]; COMP SCIENT [14.69 h] | 12,009.5 | 11,698.52 | 14015.056 | 11698.517818 | CHUDAKOV | 1 | 1 | D | S | EUGENE C | ST |  | 11-006 | 11-026 | 12-021 | 12-040 |  |  |  |  |  |  |  |  |  |
| 182432090 |  | Re-Baseline Actuals Adjustment | 1d | 2013-08-30 A | 2013-08-30 A |  | 100% | 2013-09-03 | 2013-09-03 |  |  | PROCUREMENT>$50K 69 NO ESCALATION | -124,945.8 |  |  |  |  |  |  |  |  |  |  |  |  |  |  |  |  | 100 | ADJ |  |  |  |  |  |  |
| 282432010 |  | Check-out Alarm Sys | 128d | 2013-11-26 | 2014-06-09 | 2532230 FS+11d, 2532230a FS+11d |  |  |  | 79d | 8/5 M-F w/JLAB Holidays ReBaseline | VISTNG USERS [80 h]; SCIENTIST [40 h] | 4,654.4 |  |  | 0 | CHUDAKOV | 1 | 1 | D | U | EUGENE C |  |  | 11-006 | 11-026 | 12-021 | 12-040 | 12-054 |  |  | 282432010 | 13-007 | EJ | 13-015 | PR | 14-001 |
| 282432005 |  | Check-out Monitoring | 106d | 2014-03-07 | 2014-08-05 | 2532080 FS+22d, 2532080a FS+22d |  |  |  | 39d | 8/5 M-F w/JLAB Holidays ReBaseline | VISTNG USERS [80 h]; SCIENTIST [80 h] | 7,661.6 |  |  | 0 | CHUDAKOV | 1 | 1 | D | U | EUGENE C |  |  | 11-006 | 11-026 | 12-021 | 12-040 | 12-054 |  |  | 282432005 | 13-007 | EJ | 13-015 | PR | 14-001 |
| 282432015 |  | Check-out Archiving Sys | 108d | 2014-04-29 | 2014-09-30 | 2532250, 2532250a |  |  |  | 0d | 8/5 M-F w/JLAB Holidays ReBaseline | VISTNG USERS [80 h]; SCIENTIST [80 h] | 7,661.6 |  |  | 0 | CHUDAKOV | 1 | 1 | D | U | EUGENE C |  |  | 11-006 | 11-026 | 12-021 | 12-040 |  |  |  | 282432015 | 13-007 | EJ | 13-015 | PR | 14-001 |
| 282432025 |  | Check-out Storage Mngmnt Software | 58d | 2014-07-08 | 2014-09-26 | 2532100 FS+78d |  |  |  | 2d | 8/5 M-F w/JLAB Holidays ReBaseline | SR STAFF [80 h]; SCIENTIST [40 h] | 12,632.8 |  |  | 0 | CHUDAKOV | 1 | 1 | D | U | EUGENE C |  |  | 11-006 | 11-026 | 12-021 | 12-040 |  |  |  | 282432025 | 13-007 | EJ | 13-015 | PR | 14-001 |

Notes:
- 182431000: Steps: Check-out Counting House & Equip (DAQ) (done)
- 182431010: Steps: Check-out DAQ Electrnc's (DAQ) (done)
- 182432080: Steps: Check-out Experiment Control Software DAQ Interface (done)
- 182432000: Steps: Check-out Front-End Software (done)
- 182432005: Steps: Check-out Monitoring (done)
- 182432010: Steps: Check-out Alarm Sys (done)
- 182432015: Steps: Check-out Archiving Sys (done)
- 182432020: Steps: Check-out Event Displays (done)
- 182432025: Steps: Check-out Storage Mngmnt Software (done)
- 182432030: Steps: Check-out Experiment Control Software Framework (done)
- 182432035: Steps: Check-out Experiment Control Software Display Manegement (done)
- 182432040: Steps: Check-out Experiment Control Software Backup/Restore (done)
- 182432045: Steps: Check-out Experiment Control Software Magnet PS (done)
- 182432050: Steps: Check-out Experiment Control Software HV (done)
- 182432055: Steps: Check-out Experiment Control Software LV (done)
- 182432060: Steps: Check-out Experiment Control Software Motors (done)
- 182432065: Steps: Check-out Experiment Control Software Gas Systems (done)
- 182432070: Steps: Check-out Experiment Control Software Temperature (done)
- 182432075: Steps: Check-out Experiment Control Software Target (done)
- 182432085: Steps: Level 1 Trigger Expert Software (done)

| ID | WBS | Activity | Duration | Start | Finish | Predecessors | Complete | Remaining | Planned start | Planned finish | Total float | Free float | Calendar | Resources | Cost | Actual cost | Calculated Remaining Total Cost | MONTHLY EV COST | RESP - Responsibility | STRT%COMP for CM EVM | FNSH%COMP for CM EVM | HALL D Related Milestones | CR 07-024 | EVMS Reporting Codes | CAM RESPONSIBLE | Duplications | CR 09-012 | CR 11-006 | CR 11-026 | CR 12-021 | CR 12-040 | CR 07-027 | CR 11-049 | CR 12-053 | Activities with Steps | Claimed Material Divider | ReBaseline Actuals Adjustment | Original Activity ID Rebaseline | PRIOR MONTH EV COST | BOE Labor | CR 13-015 | Post Rebaseline | CR 14-001 | MARCH!!! | CR 12-054 | CR 13-007 |
| --- | --- | --- | --- | --- | --- | --- | --- | --- | --- | --- | --- | --- | --- | --- | --- | --- | --- | --- | --- | --- | --- | --- | --- | --- | --- | --- | --- | --- | --- | --- | --- | --- | --- | --- | --- | --- | --- | --- | --- | --- | --- | --- | --- | --- | --- | --- |
|  | 4 | **1.8.2.4.4 HALL D TRIGGER AND ELECTRONICS CHECKOUT** |  | 2012-10-01 | 2014-09-26 |  |  |  |  |  |  |  |  |  |  |  |  |  |  |  |  |  |  |  |  |  |  |  |  |  |  |  |  |  |  |  |  |  |  |  |  |  |  |  |  |  |
|  | 3 | **1.8.2.4.4.3 HALL D TRIGGER BOARDS ACCEPTANCE TESTING** |  | 2012-10-01 | 2014-09-26 |  |  |  |  |  |  |  |  |  |  |  |  |  |  |  |  |  |  |  |  |  |  |  |  |  |  |  |  |  |  |  |  |  |  |  |  |  |  |  |  |  |
| 182443000 |  | Acceptance test of TS board (FE grp) | 11d | 2012-10-01 A | 2012-10-15 A | 1543020 FS-65d | 100% |  |  |  |  |  |  | ELEC ENG [240 h] | 17,474.4 | 17,474.4 | 0 | 17474.4 | CHUDAKOV | 1 | 1 | D | 07-024 | U | EUGENE C | DUP | 09-012 | 11-006 | 11-026 | 12-021 | 12-040 |  |  |  |  |  |  |  |  |  |  |  |  |  |  |  |
| 182443005 |  | Acceptance test of TI boards (FE grp) FY13 | 72d | 2012-11-05 A | 2012-11-19 A | 1543045 | 100% |  | 2013-02-01 | 2013-05-14 |  |  |  | ELEC ENG [155.68 h] | 11,335.06 | 11,335.06 | 0 | 11335.0608 | CHUDAKOV | 1 | 1 | D | 07-024 | U | EUGENE C |  |  | 11-006 | 11-026 | 12-021 | 12-040 | 07-027 | 11-049 | 12-053 |  |  |  |  |  |  |  |  |  |  |  |  |
| 182443015 |  | Acceptance test of SSP boards (FE grp) | 98d | 2013-03-04 A | 2013-05-13 A | 1543070 FS-55d | 100% |  | 2013-04-01 | 2013-08-16 |  |  |  | ELEC ENG [320 h] | 23,299.2 | 23,299.2 | 0 | 23299.2 | CHUDAKOV | 1 | 1 | D |  | U | EUGENE C |  |  | 11-006 | 11-026 | 12-021 | 12-040 |  | 11-049 |  |  |  |  |  |  |  |  |  |  |  |  |  |
| 182443010 |  | Acceptance test of CTP boards (FE grp) | 74d | 2013-05-06 A | 2013-08-30 A | 1543025 FS-40d | 100% |  | 2013-07-03 | 2013-10-16 |  |  |  | ELEC ENG [320 h] | 23,419.59 | 23,299.2 | 22600.224 | 23299.2 | CHUDAKOV | 1 | 1 | D | 07-024 | U | EUGENE C |  | 09-012 | 11-006 | 11-026 | 12-021 | 12-040 | 07-027 | 11-049 |  |  |  |  |  |  |  |  |  |  |  |  |  |
| 182443020 |  | Acceptance test of GTP boards (FE grp) | 57d | 2013-08-30 A | 2013-08-30 A | 1543085a FS-15d, 1543085 FS-15d | 100% |  | 2013-09-03 | 2013-11-20 |  |  |  | ELEC ENG [280 h] | 20,808.47 | 20,386.8 | 20386.8 | 20386.8 | CHUDAKOV | 1 | 1 | D | 07-024 | U | EUGENE C |  |  | 11-006 | 11-026 | 12-021 | 12-040 | 07-027 | 11-049 |  |  |  |  |  |  |  |  |  |  |  |  |  |
| 182443025 |  | Trigger Calibration (Hall D grp) | 178d | 2013-08-30 A | 2013-08-30 A | 1543130, 9-120M FS+120d, 1543140a, 1543135 | 100% |  | 2013-09-17 | 2014-06-06 |  |  |  | ELEC ENG [157.7 h]; SCIENTIST [210.25 h] | 27,606.64 | 26,800.95 | 29152.1813 | 26800.952226 | CHUDAKOV | 1 | 1 | D | 07-024 | S | EUGENE C |  |  | 11-006 | 11-026 | 12-021 | 12-040 | 07-027 |  |  | ST |  |  |  |  |  |  |  |  |  |  |  |
| 182443030 |  | Re-Baseline Actuals Adjustment | 1d | 2013-08-30 A | 2013-08-30 A |  | 100% |  | 2013-09-03 | 2013-09-03 |  |  |  | PROCUREMENT>$50K 69 NO ESCALATION | -62,736.65 |  |  |  |  |  |  |  |  |  |  |  |  |  |  |  |  |  |  |  |  | 100 | ADJ |  |  |  |  |  |  |  |  |  |
| 282443010 |  | Acceptance test of CTP boards (FE grp) FY13 | 20d | 2013-09-03 A | 2014-01-31 | 2543025 FS-80d, 2543030 FS-20d | 70% | 55d | 2013-10-01 | 2013-10-28 | 150d | 0d | 8/5 M-F w/JLAB Holidays ReBaseline | ELEC ENG [182.59 h] | 13,717.99 | 5,932.67 |  | 5317.75116 | CHUDAKOV | 1 | 1 | D | 07-024 | U | EUGENE C |  | 09-012 | 11-006 | 11-026 | 12-021 | 12-040 | 07-027 | 11-049 |  |  |  |  | 282443010 | 3988.31337 | EJ | 13-015 | PR |  |  |  |  |
| 282443010a |  | Acceptance test of CTP boards (FE grp) FY14 | 14d | 2013-09-03 A | 2014-01-31 | 282443010 FS-55d | 70% | 55d | 2013-10-01 | 2013-10-18 | 150d | 72d | 8/5 M-F w/JLAB Holidays ReBaseline | ELEC ENG [127.81 h] | 9,602.37 | 4,152.77 |  | 3840.94612 | CHUDAKOV | 1 | 1 | D | 07-024 | U | EUGENE C |  | 09-012 | 11-006 | 11-026 | 12-021 | 12-040 | 07-027 | 11-049 |  |  |  |  | 282443010 | 2880.70959 | EJ | 13-015 | PR | 14-001 |  |  |  |
| 282443020 |  | Acceptance test of GTP boards (FE grp) FY13 | 57d | 2013-09-03 A | 2013-09-23 A | 9-130M FS+228d | 100% |  | 2013-10-01 | 2013-12-20 |  |  | 8/5 M-F w/JLAB Holidays ReBaseline | ELEC ENG [98.25 h] | 7,381.52 | 7,153.58 |  | 0 | CHUDAKOV | 1 | 1 | D | 07-024 | U | EUGENE C |  |  | 11-006 | 11-026 | 12-021 | 12-040 | 07-027 | 11-049 |  |  |  |  | 282443020 | 7153.5825 | EJ | 13-015 | PR |  |  |  |  |
| 282443020a |  | Acceptance test of GTP boards (FE grp) FY14 | 37d | 2013-09-03 A | 2013-09-23 A | 282443020 | 100% |  | 2013-10-01 | 2013-11-20 |  |  | 8/5 M-F w/JLAB Holidays ReBaseline | ELEC ENG [181.75 h] | 13,654.88 | 13,233.22 |  | 0 | CHUDAKOV | 1 | 1 | D | 07-024 | U | EUGENE C |  |  | 11-006 | 11-026 | 12-021 | 12-040 | 07-027 | 11-049 |  |  |  |  | 282443020 | 13654.8775 | EJ | 13-015 | PR | 14-001 |  |  |  |
| 282443025a5 |  | Acceptance test of TS boards (FE_grp) FY13 | 20d | 2013-10-01 A | 2013-10-21 A | 9-130M FS+228d, 2543155 FS-286d | 100% |  | 2013-11-01 | 2013-12-02 |  |  | 8/5 M-F w/JLAB Holidays ReBaseline | ELEC ENG [45.71 h] | 3,434.19 | 3,434.19 |  | 3328.1451 | CHUDAKOV | 1 | 1 | D | 07-024 | U | EUGENE C |  |  | 11-006 | 11-026 | 12-021 | 12-040 | 07-027 |  |  |  |  |  | 282443025a5 |  | EJ | 13-015 | PR |  |  |  |  |
| 282443025a5a |  | Acceptance test of TS boards (FE_grp) FY14 | 15d | 2013-10-01 A | 2013-10-21 A | 282443025a5 | 100% |  | 2013-12-03 | 2014-01-02 |  |  | 8/5 M-F w/JLAB Holidays ReBaseline | ELEC ENG [34.29 h] | 2,576.21 | 2,576.21 |  | 2576.2077 | CHUDAKOV | 1 | 1 | D | 07-024 | U | EUGENE C |  |  | 11-006 | 11-026 | 12-021 | 12-040 | 07-027 |  |  |  |  |  | 282443025a5 |  | EJ | 13-015 | PR | 14-001 |  |  |  |
| 282443025a |  | Trigger Calibration (Hall D grp) | 184d | 2014-01-08 | 2014-09-26 | 9-140M FS+63d |  |  |  |  | 2d |  | 8/5 M-F w/JLAB Holidays ReBaseline | SCIENTIST [280 h] | 21,050.4 |  |  | 0 | CHUDAKOV | 1 | 1 | D | 07-024 | S | EUGENE C |  |  | 11-006 | 11-026 | 12-021 | 12-040 | 07-027 |  |  | ST |  |  | 282443025a |  | EJ | 13-015 | PR | 14-001 |  |  |  |
|  | 6 | **1.8.2.4.4.6 HALL D DETECTOR ELECTRONICS BOARDS CHECKOUT** |  | 2012-11-05 | 2013-11-22 |  |  |  |  |  |  |  |  |  |  |  |  |  |  |  |  |  |  |  |  |  |  |  |  |  |  |  |  |  |  |  |  |  |  |  |  |  |  |  |  |  |
| 182446005 |  | Test BCAL Readout System | 30d | 2012-11-05 A | 2013-08-30 A | 1546330, 182446000 FS-90d | 100% |  | 2013-03-19 | 2013-04-29 |  |  |  | ELEC TECH [136 h]; ELEC ENG [28 h] | 8,232.12 | 8,232.12 | 4116.06 | 8232.12 | CHUDAKOV | 1 | 1 | D |  | H | EUGENE C |  |  | 11-006 | 11-026 | 12-021 | 12-040 |  |  |  |  |  |  |  |  |  |  |  |  | XX |  |  |
| 182446000 |  | Test Power Distribution FY13 | 10d | 2013-08-30 A | 2013-08-30 A | 1546380 | 100% |  | 2013-09-30 | 2013-10-11 |  |  |  | ELEC ENG [33.1 h] | 2,479.12 | 2,410.01 | 2410.011 | 2410.011 | CHUDAKOV | 1 | 1 | D |  | H | EUGENE C |  |  | 11-006 | 11-026 | 12-021 | 12-040 |  |  | 12-053 |  |  |  |  |  |  |  |  |  |  |  |  |
| 182446010 |  | Test Pair Spectrometer PS Readout Board | 29d | 2013-08-30 A | 2013-08-30 A | 1546425, 9-130M FS+45d | 100% |  | 2013-10-28 | 2013-12-09 |  |  |  | ELEC ENG [34 h]; ELEC TECH [68 h] | 5,749.74 | 5,572.26 | 5572.26 | 5572.26 | CHUDAKOV | 1 | 1 | D |  | H | EUGENE C |  |  | 11-006 | 11-026 | 12-021 | 12-040 |  |  | 12-053 |  |  |  |  |  |  |  |  |  |  | 12-054 |  |
| 182446015 |  | Test Pair Spectrometer Transition Board | 30d | 2013-08-30 A | 2013-08-30 A | 1546430 FS-15d | 100% |  | 2013-10-07 | 2013-11-15 |  |  |  | ELEC TECH [34 h] | 1,597.66 | 1,548.36 | 1548.36 | 1548.36 | CHUDAKOV | 1 | 1 | D |  | H | EUGENE C |  |  | 11-006 | 11-026 | 12-021 | 12-040 |  |  | 12-053 |  |  |  |  |  |  |  |  |  |  | 12-054 |  |
| 182446020 |  | Test Pair Spectrometer Power Distribution | 30d | 2013-08-30 A | 2013-08-30 A | 1546435 FS-5d | 100% |  | 2013-10-21 | 2013-12-03 |  |  |  | ELEC TECH [34 h] | 1,597.66 | 1,548.36 | 1548.36 | 1548.36 | CHUDAKOV | 1 | 1 | D |  | H | EUGENE C |  |  | 11-006 | 11-026 | 12-021 | 12-040 |  |  | 12-053 |  |  |  |  |  |  |  |  |  |  | 12-054 |  |
| 182446025 |  | Test Pair Spectrometer System | 23d | 2013-08-30 A | 2013-08-30 A | 182446015, 182446010, 1546440 FS-13d, 182446020 | 100% |  | 2013-12-10 | 2014-01-17 |  |  |  | ELEC ENG [34 h]; ELEC TECH [68 h] | 5,749.74 | 5,572.26 | 5572.26 | 5572.26 | CHUDAKOV | 1 | 1 | D |  | H | EUGENE C |  |  | 11-006 | 11-026 | 12-021 | 12-040 |  |  |  |  |  |  |  |  |  |  |  |  |  | 12-054 |  |
| 182446030 |  | Test Start Counter Readout Board | 24d | 2013-08-30 A | 2013-08-30 A | 1546525 FS-14d | 100% |  | 2013-09-03 | 2013-10-04 |  |  |  | ELEC ENG [34 h]; ELEC TECH [68 h] | 5,601.84 | 5,572.26 | 5572.26 | 5572.26 | CHUDAKOV | 1 | 1 | D |  | H | EUGENE C |  |  | 11-006 | 11-026 | 12-021 | 12-040 |  |  |  |  |  |  |  |  |  |  |  |  |  |  |  |
| 182446035 |  | Test Start Counter Transition Board | 24d | 2013-08-30 A | 2013-08-30 A | 1546530 FS+13d | 100% |  | 2013-09-03 | 2013-10-04 |  |  |  | ELEC TECH [34 h] | 1,556.58 | 1,548.36 | 1548.36 | 1548.36 | CHUDAKOV | 1 | 1 | D |  | H | EUGENE C |  |  | 11-006 | 11-026 | 12-021 | 12-040 |  |  |  |  |  |  |  |  |  |  |  |  |  |  |  |
| 182446040 |  | Test Start Counter Power Distribution | 29d | 2013-08-30 A | 2013-08-30 A | 1546535 FS+5d | 100% |  | 2013-09-03 | 2013-10-11 |  |  |  | ELEC TECH [34 h] | 1,563.66 | 1,548.36 | 1548.36 | 1548.36 | CHUDAKOV | 1 | 1 | D |  | H | EUGENE C |  |  | 11-006 | 11-026 | 12-021 | 12-040 |  |  |  |  |  |  |  |  |  |  |  |  |  |  |  |
| 182446045 |  | Re-Baseline Actuals Adjustment | 1d | 2013-08-30 A | 2013-08-30 A |  | 100% |  | 2013-09-03 | 2013-09-03 |  |  |  | PROCUREMENT>$50K 69 NO ESCALATION | -33,552.35 |  |  |  |  |  |  |  |  |  |  |  |  |  |  |  |  |  |  |  |  | 100 | ADJ |  |  |  |  |  |  |  |  |  |
| 282446000 |  | Test Power Distribution FY13 | 16d | 2013-10-01 A | 2013-11-15 | 9-130M FS+232d | 55% | 11d | 2013-11-01 | 2013-11-22 | 213d | 29d | 8/5 M-F w/JLAB Holidays ReBaseline | ELEC ENG [12.8 h]; ELEC TECH [25.6 h] | 2,164.6 | 1,464.3 |  | 1153.7856 | CHUDAKOV | 1 | 1 | D |  | U | EUGENE C |  |  | 11-006 | 11-026 | 12-021 | 12-040 |  |  | 12-053 |  |  |  | 282446000 |  | PE | 13-015 | PR |  |  |  | 13-007F |
| 282446000a |  | Test Power Distribution FY14 | 34d | 2013-10-01 A | 2013-11-15 | 282446000 FS-40d | 55% | 11d | 2013-11-25 | 2014-01-24 | 213d |  | 8/5 M-F w/JLAB Holidays ReBaseline | ELEC ENG [27.2 h]; ELEC TECH [54.4 h] | 4,599.8 | 3,111.62 |  | 2529.8856 | CHUDAKOV | 1 | 1 | D |  | U | EUGENE C |  |  | 11-006 | 11-026 | 12-021 | 12-040 |  |  | 12-053 |  |  |  | 282446000 |  | PE | 13-015 | PR | 14-001 |  |  | 13-007F |
| 282446010 |  | Test Pair Spectrometer PS Readout Board | 34d | 2013-10-01 A | 2013-11-21 | 2546425 FS+4d | 50% | 15d | 2013-11-01 | 2013-12-20 | 219d | 19d | 8/5 M-F w/JLAB Holidays ReBaseline | ELEC TECH [80 h]; ELEC ENG [40 h] | 6,764.4 | 4,094.25 |  | 3382.2 | CHUDAKOV | 1 | 1 | D |  | U | EUGENE C |  |  | 11-006 | 11-026 | 12-021 | 12-040 |  |  | 12-053 |  |  |  | 282446010 |  | PE | 13-015 | PR | 14-001 |  | 12-054 |  |
| 282446015a |  | Test Pair Spectrometer Transition Board | 34d | 2013-10-01 A | 2013-11-21 | 2546430 FS+4d | 50% | 15d | 2013-11-01 | 2013-12-20 | 219d | 19d | 8/5 M-F w/JLAB Holidays ReBaseline | ELEC TECH [40 h] | 1,879.6 | 1,137.65 |  | 939.8 | CHUDAKOV | 1 | 1 | D |  | U | EUGENE C |  |  | 11-006 | 11-026 | 12-021 | 12-040 |  |  | 12-053 |  |  |  | 282446015a |  | PE | 13-015 | PR | 14-001 |  | 12-054 |  |
| 282446020 |  | Test Pair Spectrometer Power Distribution | 34d | 2013-10-01 A | 2013-11-20 | 2546435 FS+4d | 50% | 14d | 2013-11-01 | 2013-12-20 | 220d | 20d | 8/5 M-F w/JLAB Holidays ReBaseline | ELEC TECH [40 h] | 1,879.6 | 1,168.4 |  | 939.8 | CHUDAKOV | 1 | 1 | D |  | U | EUGENE C |  |  | 11-006 | 11-026 | 12-021 | 12-040 |  |  | 12-053 |  |  |  | 282446020 |  | PE | 13-015 | PR | 14-001 |  | 12-054 |  |
| 282446025 |  | Test Pair Spectrometer System | 34d | 2013-10-01 A | 2013-11-20 | 282446020 FS-34d, 282446015a FS-34d, 282446010 FS-34d, 2546430 FS+4d | 30% | 14d | 2013-11-01 | 2013-12-20 | 200d | 48d | 8/5 M-F w/JLAB Holidays ReBaseline | ELEC ENG [40 h]; ELEC TECH [80 h] | 6,764.4 | 4,204.9 |  | 2029.32 | CHUDAKOV | 1 | 1 | D |  | U | EUGENE C |  |  | 11-006 | 11-026 | 12-021 | 12-040 |  |  |  |  |  |  | 282446025 |  | PE | 13-015 | PR | 14-001 |  | 12-054 |  |
| 282446030 |  | Test Start Counter Readout Board FY13 | 16d | 2013-10-01 A | 2013-11-22 | 9-130M FS+232d | 40% | 16d | 2013-11-01 | 2013-11-22 | 198d | 4d | 8/5 M-F w/JLAB Holidays ReBaseline | ELEC ENG [11.85 h]; ELEC TECH [23.71 h] | 2,004.42 | 1,182.09 |  | 777.0571164 | CHUDAKOV | 1 | 1 | D |  | U | EUGENE C |  |  | 11-006 | 11-026 | 12-021 | 12-040 |  |  |  |  |  |  | 282446030 |  | PE | 13-015 | PR |  |  |  |  |
| 282446030a |  | Test Start Counter Readout Board FY14 | 38d | 2013-10-01 A | 2013-11-22 | 282446030 FS-20d | 40% | 16d | 2013-11-25 | 2014-01-30 | 198d |  | 8/5 M-F w/JLAB Holidays ReBaseline | ELEC ENG [28.15 h]; ELEC TECH [56.29 h] | 4,759.88 | 2,807.11 |  | 1903.953124 | CHUDAKOV | 1 | 1 | D |  | U | EUGENE C |  |  | 11-006 | 11-026 | 12-021 | 12-040 |  |  |  |  |  |  | 282446030 |  | PE | 13-015 | PR | 14-001 |  |  |  |
| 282446035 |  | Test Start Counter Transition Board FY13 | 16d | 2013-10-01 A | 2013-11-22 | 9-130M FS+232d | 25% | 16d | 2013-11-01 | 2013-11-22 | 198d | 4d | 8/5 M-F w/JLAB Holidays ReBaseline | ELEC TECH [21.76 h] | 1,022.5 | 603.01 |  | 247.7376 | CHUDAKOV | 1 | 1 | D |  | U | EUGENE C |  |  | 11-006 | 11-026 | 12-021 | 12-040 |  |  |  |  |  |  | 282446035 |  | PE | 13-015 | PR |  |  |  |  |
| 282446035a |  | Test Start Counter Transition Board FY14 | 9d | 2013-10-01 A | 2013-11-22 | 282446035 FS-20d | 25% | 16d | 2013-11-25 | 2013-12-09 | 198d |  | 8/5 M-F w/JLAB Holidays ReBaseline | ELEC TECH [12.24 h] | 575.16 | 339.2 |  | 143.7894 | CHUDAKOV | 1 | 1 | D |  | U | EUGENE C |  |  | 11-006 | 11-026 | 12-021 | 12-040 |  |  |  |  |  |  | 282446035 |  | PE | 13-015 | PR | 14-001 |  |  |  |
| 282446040 |  | Test Start Counter Power Distribution FY13 | 16d | 2013-10-01 A | 2013-11-22 | 9-130M FS+232d | 50% | 16d | 2013-11-01 | 2013-11-22 | 198d | 4d | 8/5 M-F w/JLAB Holidays ReBaseline | ELEC TECH [13.6 h] | 639.06 | 376.88 |  | 309.672 | CHUDAKOV | 1 | 1 | D |  | U | EUGENE C |  |  | 11-006 | 11-026 | 12-021 | 12-040 |  |  |  |  |  |  | 282446040 |  | PE | 13-015 | PR |  |  |  |  |
| 282446040a |  | Test Start Counter Power Distribution FY14 | 24d | 2013-10-01 A | 2013-11-22 | 282446040 FS-20d | 50% | 16d | 2013-11-25 | 2014-01-09 | 198d |  | 8/5 M-F w/JLAB Holidays ReBaseline | ELEC TECH [20.4 h] | 958.6 | 565.33 |  | 479.298 | CHUDAKOV | 1 | 1 | D |  | U | EUGENE C |  |  | 11-006 | 11-026 | 12-021 | 12-040 |  |  |  |  |  |  | 282446040 |  | PE | 13-015 | PR | 14-001 |  |  |  |

Notes:
- 182443025: Steps: Trigger Calibration (Hall D grp) (done)
- 282443025a: Steps: calibrate BCAL; calibrate FCAL; calibrate Tagger Detectors; calibrate PS; SC; and TOF

| ID | WBS | Activity | Duration | Start | Finish | Predecessors | Complete | Remaining | Planned start | Planned finish | Total float | Free float | Calendar | Resources | Cost | Actual cost | Original Activity ID Rebaseline | MONTHLY EV COST | RESP - Responsibility | STRT%COMP for CM EVM | FNSH%COMP for CM EVM | HALL D Related Milestones | EVMS Reporting Codes | CAM RESPONSIBLE | CR 11-026 | CR 12-021 | CR 12-055 | CR 13-007 | BOE Labor | CR 13-015 | Post Rebaseline | Temple/Lehman | CR 14-001 | CR 11-004 | CR 11-006 | CR 12-054 | 12 GeV 1st level Critical Path | CR 07-024 | CR 09-014 | CR 10-042 | CR 09-027 | CR 09-027 Repair | Remaining Material Cost Based on % Compl | Claimed Material Cost Based on % Complet | Initial Claimed Material Calc | Claimed Material Divider | ReBaseline Actuals Adjustment | LOE Divider | LOE Multiplier | PRIOR MONTH EV COST | CR 10-037 | CR 10-050 | CR 11-007 | CR 12-038 | BOE Expenses | LOE % Pre Calc | LOE % | CR 11-018 |
| --- | --- | --- | --- | --- | --- | --- | --- | --- | --- | --- | --- | --- | --- | --- | --- | --- | --- | --- | --- | --- | --- | --- | --- | --- | --- | --- | --- | --- | --- | --- | --- | --- | --- | --- | --- | --- | --- | --- | --- | --- | --- | --- | --- | --- | --- | --- | --- | --- | --- | --- | --- | --- | --- | --- | --- | --- | --- | --- |
|  | 5 | **1.8.2.4.5 HALL D BEAMLINE** |  | 2013-11-01 | 2014-09-04 |  |  |  |  |  |  |  |  |  |  |  |  |  |  |  |  |  |  |  |  |  |  |  |  |  |  |  |  |  |  |  |  |  |  |  |  |  |  |  |  |  |  |  |  |  |  |  |  |  |  |  |  |  |
|  | 3 | **1.8.2.4.5.3 HALL D BEAMLINE COMPONENT TESTING** |  | 2013-11-01 | 2014-09-04 |  |  |  |  |  |  |  |  |  |  |  |  |  |  |  |  |  |  |  |  |  |  |  |  |  |  |  |  |  |  |  |  |  |  |  |  |  |  |  |  |  |  |  |  |  |  |  |  |  |  |  |  |  |
| 282453010 |  | Test PS High Granularity Counters FY13 | 20d | 2013-11-01 | 2013-12-02 | 2553042 FS-20d |  |  |  |  | 170d | 0d | 8/5 M-F w/JLAB Holidays ReBaseline | ELEC ENG [18.18 h]; ELEC TECH [18.18 h]; SCIENTIST [54.55 h] | 6,321.15 |  | 2553043 | 0 | CHUDAKOV | 1 | 1 | D | U | EUGENE C | 11-026 | 12-021 | 12-055 | 13-007F | PE | 13-015 | PR | LR13 |  |  |  |  |  |  |  |  |  |  |  |  |  |  |  |  |  |  |  |  |  |  |  |  |  |  |
| 282453010a |  | Test PS High Granularity Counters FY14 | 24d | 2013-12-03 | 2014-01-15 | 282453010 |  |  |  |  | 170d | 18d | 8/5 M-F w/JLAB Holidays ReBaseline | ELEC ENG [21.82 h]; ELEC TECH [21.82 h]; SCIENTIST [65.45 h] | 7,585.25 |  | 2553043 | 0 | CHUDAKOV | 1 | 1 | D | U | EUGENE C | 11-026 | 12-021 | 12-055 | 13-007F | PE | 13-015 | PR | LR13 | 14-001 |  |  |  |  |  |  |  |  |  |  |  |  |  |  |  |  |  |  |  |  |  |  |  |  |  |
| 282453000 |  | Check Operation of Goniometer (BL Compnts) | 160d | 2014-01-21 | 2014-09-04 | 2553165 FS-42d, 2553170 FS-120d, 2553145 FS-80d, 2553147 FS-80d |  |  |  |  | 18d | 0d | 8/5 M-F w/JLAB Holidays ReBaseline | SCIENTIST [320 h] | 24,057.6 |  | 2553025 | 0 | CHUDAKOV | 1 | 1 | D | S | EUGENE C | 11-026 | 12-021 |  | 13-007 | EJ | 13-015 | PR | LR13 | 14-001 | 11-004 | 11-006 | 12-054 |  |  |  |  |  |  |  |  |  |  |  |  |  |  |  |  |  |  |  |  |  |  |
|  | 6 | **1.8.2.4.6 HALL D INFRASTUCTURE** |  | 2013-12-04 | 2014-08-29 |  |  |  |  |  |  |  |  |  |  |  |  |  |  |  |  |  |  |  |  |  |  |  |  |  |  |  |  |  |  |  |  |  |  |  |  |  |  |  |  |  |  |  |  |  |  |  |  |  |  |  |  |  |
|  | 2 | **1.8.2.4.6.2 HALL D INSTALLATION TESTING** |  | 2013-12-04 | 2014-08-29 |  |  |  |  |  |  |  |  |  |  |  |  |  |  |  |  |  |  |  |  |  |  |  |  |  |  |  |  |  |  |  |  |  |  |  |  |  |  |  |  |  |  |  |  |  |  |  |  |  |  |  |  |  |
| 282462050 |  | System Check-out Install Hall FCAL | 20d | 2013-12-04 | 2014-01-10 | 2562475c, 2562700 |  |  |  |  | 183d |  | 8/5 M-F w/JLAB Holidays ReBaseline | ELEC TECH [240 h]; ELEC ENG [120 h] | 20,293.2 |  | 2562590 | 0 | CHUDAKOV | 1 | 1 | D | S | EUGENE C | 11-026 | 12-021 |  | 13-007 | PE | 13-015 | PR | LR13 | 14-001 |  | 11-006 | 12-054 | 1 |  |  |  |  |  |  |  |  |  |  |  |  |  |  |  |  |  |  |  |  |  |
| 282462040 |  | System Check-out Install Hall BCAL | 90d | 2014-01-02 | 2014-05-08 | 2562275c, 2546660, 2562540 |  |  |  |  | 100d |  | 8/5 M-F w/JLAB Holidays ReBaseline | ELEC TECH [240 h]; ELEC ENG [120 h] | 20,293.2 |  | 2562580 | 0 | CHUDAKOV | 1 | 1 | D | S | EUGENE C | 11-026 | 12-021 |  | 13-007 | PE | 13-015 | PR | LR13 | 14-001 |  | 11-006 | 12-054 | 1 |  |  |  |  |  |  |  |  |  |  |  |  |  |  |  |  |  |  |  |  |  |
| 282462005 |  | Operation Checks FDC (outside Solenoid) (Installtn) | 22d | 2014-01-07 | 2014-02-06 | 25211191 FS-100d, 2562370 FS-2d, 2562370c FS-56d |  |  |  |  | 16d | 0d | 8/5 M-F w/JLAB Holidays ReBaseline | MECH ENG [16 h]; ELEC ENG [40 h]; MECH TECH [80 h]; ELEC TECH [160 h]; SCIENTIST [240 h] | 33,547.12 |  | 2562375 | 0 | CHUDAKOV | 1 | 1 | D | S | EUGENE C | 11-026 | 12-021 |  | 13-007 | PE | 13-015 | PR | LR13 | 14-001 |  | 11-006 | 12-054 |  | 07-024 | 09-014 | 10-042 |  |  |  |  |  |  |  |  |  |  |  |  |  |  |  |  |  |  |
| 282462020 |  | System Check-out Install Hall Pair Spectrometer | 10d | 2014-02-12 | 2014-02-25 | 282453010a, 2562246, 282446025, 282453010, 2562520, 2562099c FS+3d |  |  |  |  | 152d |  | 8/5 M-F w/JLAB Holidays ReBaseline | ELEC TECH [80 h]; ELEC ENG [40 h] | 6,764.4 |  | 2562560 | 0 | CHUDAKOV | 1 | 1 | D | S | EUGENE C | 11-026 | 12-021 |  | 13-007 | PE | 13-015 | PR | LR13 | 14-001 |  | 11-006 | 12-054 | 1 |  |  |  |  |  |  |  |  |  |  |  |  |  |  |  |  |  |  |  |  |  |
| 282462010 |  | Operation Checks FDC (Inside Solenoid) (Installtn) | 127d | 2014-02-28 | 2014-08-27 | 2562385, 2562393 |  |  |  |  | 23d |  | 8/5 M-F w/JLAB Holidays ReBaseline | ELEC ENG [80 h]; MECH ENG [40 h]; MECH TECH [120 h]; ELEC TECH [80 h]; SCIENTIST [560 h] | 60,535.6 |  | 2562390 | 0 | CHUDAKOV | 1 | 1 | D | S | EUGENE C | 11-026 | 12-021 |  | 13-007 | PE | 13-015 | PR | LR13 | 14-001 |  | 11-006 | 12-054 |  | 07-024 | 09-014 | 10-042 |  |  |  |  |  |  |  |  |  |  |  |  |  |  |  |  |  |  |
| 282462030 |  | System Check-out Install Hall CDC | 38d | 2014-03-03 | 2014-04-23 | 2562290c, 2562750, 2562530 |  |  |  |  | 111d |  | 8/5 M-F w/JLAB Holidays ReBaseline | ELEC TECH [160 h]; ELEC ENG [80 h] | 13,528.8 |  | 2562570 | 0 | CHUDAKOV | 1 | 1 | D | S | EUGENE C | 11-026 | 12-021 |  | 13-007 | PE | 13-015 | PR | LR13 | 14-001 |  | 11-006 | 12-054 | 1 |  |  |  |  |  |  |  |  |  |  |  |  |  |  |  |  |  |  |  |  |  |
| 282462035 |  | System Check-out Install Hall FDC | 60d | 2014-03-24 | 2014-06-16 | 2562370c, 2562715, 2562535 |  |  |  |  | 74d |  | 8/5 M-F w/JLAB Holidays ReBaseline | ELEC TECH [240 h]; ELEC ENG [120 h] | 20,293.2 |  | 2562575 | 0 | CHUDAKOV | 1 | 1 | D | S | EUGENE C | 11-026 | 12-021 |  | 13-007 | PE | 13-015 | PR | LR13 | 14-001 |  | 11-006 | 12-054 | 1 |  |  |  |  |  |  |  |  |  |  |  |  |  |  |  |  |  |  |  |  |  |
| 282462000 |  | Operational Checks CDC (Inside Solenoid) (Installtn) | 94d | 2014-04-18 | 2014-08-29 | 2562301 FS+1d, 2562300, 2562280 FS-45d, 2562303 FS-10d |  |  |  |  | 2d |  | 8/5 M-F w/JLAB Holidays ReBaseline | ELEC TECH [80 h]; MECH ENG [40 h]; MECH TECH [40 h]; SCIENTIST [320 h] | 32,696.4 |  | 2562305 | 0 | CHUDAKOV | 1 | 1 | D | S | EUGENE C | 11-026 | 12-021 |  | 13-007 | PE | 13-015 | PR | LR13 | 14-001 |  | 11-006 | 12-054 | 1 | 07-024 | 09-014 | 10-042 | 09-027 | 09-027 |  |  |  |  |  |  |  |  |  |  |  |  |  |  |  |  |
| 282462045 |  | System Check-out Install Hall TOF | 20d | 2014-06-03 | 2014-06-30 | 2562545, 2562455c |  |  |  |  | 64d |  | 8/5 M-F w/JLAB Holidays ReBaseline | ELEC TECH [80 h]; ELEC ENG [40 h] | 6,764.4 |  | 2562585 | 0 | CHUDAKOV | 1 | 1 | D | S | EUGENE C | 11-026 | 12-021 |  | 13-007 | PE | 13-015 | PR | LR13 | 14-001 |  | 11-006 | 12-054 | 1 |  |  |  |  |  |  |  |  |  |  |  |  |  |  |  |  |  |  |  |  |  |
| 282462015 |  | System Check-out Install Hall Tagger | 10d | 2014-06-12 | 2014-06-25 | 2562515, 2562095c |  |  |  |  | 67d |  | 8/5 M-F w/JLAB Holidays ReBaseline | ELEC TECH [80 h]; ELEC ENG [40 h] | 6,764.4 |  | 2562555 | 0 | CHUDAKOV | 1 | 1 | D | S | EUGENE C | 11-026 | 12-021 |  | 13-007 | PE | 13-015 | PR | LR13 | 14-001 |  | 11-006 | 12-054 | 1 |  |  |  |  |  |  |  |  |  |  |  |  |  |  |  |  |  |  |  |  |  |
| 282462025 |  | System Check-out Install Hall Start Counter | 7d | 2014-08-08 | 2014-08-18 | 2562525, 2562490c FS-25d |  |  |  |  | 30d |  | 8/5 M-F w/JLAB Holidays ReBaseline | ELEC TECH [80 h]; ELEC ENG [40 h] | 6,764.4 |  | 2562565 | 0 | CHUDAKOV | 1 | 1 | D | S | EUGENE C | 11-026 | 12-021 |  | 13-007 | PE | 13-015 | PR | LR13 | 14-001 |  | 11-006 | 12-054 | 1 |  |  |  |  |  |  |  |  |  |  |  |  |  |  |  |  |  |  |  |  |  |
|  | 3 | **1.8.3 PRE-OPS SUPPORT** |  | 2013-08-30 | 2016-06-30 |  |  |  |  |  |  |  |  |  |  |  |  |  |  |  |  |  |  |  |  |  |  |  |  |  |  |  |  |  |  |  |  |  |  |  |  |  |  |  |  |  |  |  |  |  |  |  |  |  |  |  |  |  |
|  | 1 | **1.8.3.1 PRE-OPS SUPPORT - PROJECT OFFICE** |  | 2013-08-30 | 2016-06-30 |  |  |  |  |  |  |  |  |  |  |  |  |  |  |  |  |  |  |  |  |  |  |  |  |  |  |  |  |  |  |  |  |  |  |  |  |  |  |  |  |  |  |  |  |  |  |  |  |  |  |  |  |  |
| 1831950 |  | Re-Baseline Actuals Adjustment | 1d | 2013-08-30 A | 2013-08-30 A |  | 100% |  | 2013-09-03 | 2013-09-03 |  |  |  | PROCUREMENT>$50K 69 NO ESCALATION | 256,353.84 |  |  | 256353.84 |  |  |  |  |  |  |  |  |  |  |  |  |  |  |  |  |  |  |  |  |  |  |  |  | 0 | 256353.84 | 25635384 | 100 | ADJ |  |  |  |  |  |  |  |  |  |  |  |
| 2831913LOE |  | FY13 Pre-Ops Supprt - Proj Office | 20d | 2013-09-03 A | 2013-09-30 A | 9-130M FS+228d | 100% |  | 2013-10-01 | 2013-10-28 |  |  | 8/5 M-F w/JLAB Holidays ReBaseline | SCIENTIST [14.07 h]; OFFICE [140.8 h]; SUPPLIES & MATERIALS; SR STAFF [179.51 h]; DIRECTORATE [123.18 h]; ADMIN [70.4 h]; ELEC ENG [35.2 h]; MECH ENG [140.8 h] | 71,176.27 | 67,398.22 | 2831913LOE | 0 | RODE C | 1 | 1 |  | E | CLAUS R |  |  |  |  | PE | 13-015 | PR |  |  |  |  |  |  |  |  |  |  |  |  |  |  |  |  | 100 | 100 | 69025.915819 | 10-037 | 10-050 | 11-007 | 12-038 | PE |  |  |  |
| 2831914LOE |  | FY14 Pre-Ops Supprt - Proj Office | 247d | 2013-10-01 A | 2014-09-30 | 2831913LOE | 9% | 224d | 2013-11-01 | 2014-10-31 | 311d | 0d | 8/5 M-F w/JLAB Holidays ReBaseline | SCIENTIST [176 h]; OFFICE [1760 h]; SUPPLIES & MATERIALS; SR STAFF [2244 h]; DIRECTORATE [1737.4 h]; ADMIN [880 h]; ELEC ENG [440 h]; MECH ENG [1760 h] | 930,872.11 | 84,697.77 | 2831914LOE | 86664.1932548 | RODE C | 1 | 1 |  | E | CLAUS R |  |  |  |  | PE | 13-015 | PR |  | 14-001 |  |  |  |  |  |  |  |  |  |  |  |  |  |  | 100 | 100 |  | 10-037 | 10-050 | 11-007 | 12-038 | PE | 90.6882591 | 9.31174089 |  |
| 2831915LOE |  | FY15 Pre-Ops Supprt - Proj Office | 247d | 2014-10-01 | 2015-10-01 | 271914LOE, 2831914LOE |  |  |  |  | 311d | 0d | 8/5 M-F w/JLAB Holidays ReBaseline | MECH ENG [3520 h]; SR STAFF [4488 h]; SCIENTIST [352 h]; DIRECTORATE [3080 h]; OFFICE [3520 h]; ELEC ENG [880 h]; SUPPLIES & MATERIALS; ADMIN [1760 h] | 1,780,146.32 |  | 2831915LOE | 0 | RODE C | 1 | 1 |  | E | ROLF E |  |  |  |  | PE | 13-015 | PR |  | 14-001 |  |  |  |  |  |  |  |  |  |  |  |  |  |  | 100 | 100 |  |  | 10-050 |  |  | PE | 100 | 0 |  |
| 2831916LOE |  | FY16 Pre-Ops Supprt - Proj Office | 184d | 2015-10-02 | 2016-06-30 | 2831915LOE |  |  |  |  | 311d |  | 8/5 M-F w/JLAB Holidays ReBaseline | MECH ENG [2640 h]; SR STAFF [3366 h]; OFFICE [2640 h]; ELEC ENG [660 h]; DIRECTORATE [2310 h]; SUPPLIES & MATERIALS; ADMIN [1320 h]; SCIENTIST [264 h] | 1,345,428.74 |  | 2831916LOE | 0 | RODE C | 1 | 1 |  | E | ROLF E |  |  |  |  | PE | 13-015 | PR |  | 14-001 |  |  |  |  |  |  |  |  |  |  |  |  |  |  | 100 | 100 |  |  | 10-050 |  |  | PE | 100 | 0 | 11-018 |

| ID | WBS | Activity | Duration | Start | Finish | Predecessors | Complete | Remaining | Planned start | Planned finish | Total float | Free float | Calendar | Resources | Cost | Remaining Material Cost Based on % Compl | Claimed Material Cost Based on % Complet | Initial Claimed Material Calc | Claimed Material Divider | MONTHLY EV COST | ReBaseline Actuals Adjustment | Calculated Remaining Total Cost | RESP - Responsibility | STRT%COMP for CM EVM | FNSH%COMP for CM EVM | HALL D Related Milestones | EVMS Reporting Codes | CAM RESPONSIBLE | CR 10-046 | CR 11-006 | CR 11-026 | CR 12-054 | Original Activity ID Rebaseline | PRIOR MONTH EV COST | CR 13-007 | BOE Procurement | CR 13-015 | Post Rebaseline | Obligated Prior to Rebaseline |
| --- | --- | --- | --- | --- | --- | --- | --- | --- | --- | --- | --- | --- | --- | --- | --- | --- | --- | --- | --- | --- | --- | --- | --- | --- | --- | --- | --- | --- | --- | --- | --- | --- | --- | --- | --- | --- | --- | --- | --- |
|  | 2 | **1.8.3.2 PRE-OPS SUPPORT - OFFICE OF PROJECT MANAGEMENT** |  |  |  |  |  |  |  |  |  |  |  |  |  |  |  |  |  |  |  |  |  |  |  |  |  |  |  |  |  |  |  |  |  |  |  |  |  |
|  | 9 | **1.9 VA STATE** |  | 2010-03-01 | 2013-12-05 |  |  |  |  |  |  |  |  |  |  |  |  |  |  |  |  |  |  |  |  |  |  |  |  |  |  |  |  |  |  |  |  |  |  |
|  | 5 | **1.9.5 HALL D - VA STATE** |  | 2010-03-01 | 2013-12-05 |  |  |  |  |  |  |  |  |  |  |  |  |  |  |  |  |  |  |  |  |  |  |  |  |  |  |  |  |  |  |  |  |  |  |
|  | 1 | **1.9.5.1 NOT USED** |  | 2013-08-30 | 2013-08-30 |  |  |  |  |  |  |  |  |  |  |  |  |  |  |  |  |  |  |  |  |  |  |  |  |  |  |  |  |  |  |  |  |  |  |
| 1951000 |  | Re-Baseline Actuals Adjustment | 1d | 2013-08-30 A | 2013-08-30 A |  | 100% |  | 2013-09-03 | 2013-09-03 |  |  |  | PROCUREMENT>$50K 69 NO ESCALATION | 193,321.29 | 0 | 193321.29 | 19332129 | 100 | 193321.29 | ADJ |  |  |  |  |  |  |  |  |  |  |  |  |  |  |  |  |  |  |
|  | 2 | **1.9.5.2 HALL D DETECTORS** |  | 2010-03-01 | 2013-12-05 |  |  |  |  |  |  |  |  |  |  |  |  |  |  |  |  |  |  |  |  |  |  |  |  |  |  |  |  |  |  |  |  |  |  |
|  | 1 | **1.9.5.2.1 HALL D TRACKING** |  | 2010-04-06 | 2013-12-05 |  |  |  |  |  |  |  |  |  |  |  |  |  |  |  |  |  |  |  |  |  |  |  |  |  |  |  |  |  |  |  |  |  |  |
|  | 2 | **1.9.5.2.1.2 HALL D CENTRAL CHAMBERS** |  | 2010-04-06 | 2013-12-05 |  |  |  |  |  |  |  |  |  |  |  |  |  |  |  |  |  |  |  |  |  |  |  |  |  |  |  |  |  |  |  |  |  |  |
| 195212010 |  | Procurement epoxy with delivery in phases (P1 Construction Setup & Straw Penetration) | 379d | 2010-04-06 A | 2011-10-10 A | 9-100M FS+123d | 100% |  |  |  |  |  |  | PROCUREMENT<$50K 60 NO ESCALATION | 22,373 | 0 | 22373 | 2237300 | 100 | 22373 |  | 0 | CHUDAKOV | 1 | 1 | D | D | EUGENE C | 10-046 | 11-006 | 11-026 | 12-054F |  |  |  |  |  |  |  |
| 195212015 |  | Installation mandril and end plates (P1 Construction Setup & Straw Penetration) | 103d | 2010-04-06 A | 2010-08-31 A | 195212010 FS-82d | 100% |  | 2010-04-06 | 2010-08-30 |  |  |  | PROCUREMENT<$50K 60 NO ESCALATION | 6,391 | 0 | 6391 | 639100 | 100 | 6391 |  | 0 | CHUDAKOV | 1 | 1 | D | D | EUGENE C | 10-046 | 11-006 | 11-026 | 12-054F |  |  |  |  |  |  |  |
| 195212020 |  | Aligned and fix end plates (P1 Construction Setup & Straw Penetration) (P2 Straw Insertion) | 124d | 2010-04-06 A | 2010-09-29 A | 195212015 FS-82d | 100% |  |  |  |  |  |  | PROCUREMENT<$50K 60 NO ESCALATION | 19,172 | 0 | 19172 | 1917200 | 100 | 19172 |  | 0 | CHUDAKOV | 1 | 1 | D | D | EUGENE C | 10-046 | 11-006 | 11-026 | 12-054F |  |  |  |  |  |  |  |
| 195212025 |  | Straw Preparation Axial section I (P2 Straw Insertion) | 162d | 2010-04-06 A | 2010-11-22 A | 195212020 FS-82d | 100% |  |  |  |  |  |  | PROCUREMENT<$50K 60 NO ESCALATION; PROCUREMENT>$50K 69 NO ESCALATION | 3,167.5 | 0 | 3167.5 | 316750 | 100 | 3167.5 |  | 0 | CHUDAKOV | 1 | 1 | D | D | EUGENE C | 10-046 | 11-006 | 11-026 | 12-054F |  |  |  |  |  |  |  |
| 195212030 |  | Insert straws Axial section I (P2 Straw Insertion) | 198d | 2010-04-06 A | 2011-01-24 A | 195212025 FS-104d | 100% |  |  |  |  |  |  | PROCUREMENT>$50K 69 NO ESCALATION | 3,167.5 | 0 | 3167.5 | 316750 | 100 | 3167.5 |  | 0 | CHUDAKOV | 1 | 1 | D | D | EUGENE C | 10-046 | 11-006 | 11-026 | 12-054F |  |  |  |  |  |  |  |
| 195212035 |  | Straw preparation Stereo section I-L (P2 Straw Insertion) | 198d | 2010-04-06 A | 2011-01-24 A | 195212030 FS-104d | 100% |  |  |  |  |  |  | PROCUREMENT>$50K 69 NO ESCALATION | 4,701.5 | 0 | 4701.5 | 470150 | 100 | 4701.5 |  | 0 | CHUDAKOV | 1 | 1 | D | D | EUGENE C | 10-046 | 11-006 | 11-026 | 12-054F |  |  |  |  |  |  |  |
| 195212040 |  | Insert straws Stereo section 1-L (Phase 2 Straw Insertion) | 198d | 2010-04-06 A | 2011-01-24 A | 195212035 FS-104d | 100% |  |  |  |  |  |  | PROCUREMENT>$50K 69 NO ESCALATION | 4,701.5 | 0 | 4701.5 | 470150 | 100 | 4701.5 |  | 0 | CHUDAKOV | 1 | 1 | D | D | EUGENE C | 10-046 | 11-006 | 11-026 | 12-054F |  |  |  |  |  |  |  |
| 195212045 |  | Straw preparation Stereo section 1-R (P2 Straw Insertion) | 222d | 2010-04-06 A | 2011-02-28 A | 195212040 FS-104d | 100% |  |  |  |  |  |  | PROCUREMENT>$50K 69 NO ESCALATION | 6,363 | 0 | 6363 | 636300 | 100 | 6363 |  | 0 | CHUDAKOV | 1 | 1 | D | D | EUGENE C | 10-046 | 11-006 | 11-026 | 12-054F |  |  |  |  |  |  |  |
| 195212050 |  | Insert straws Stereo section 1-R (P2 Straw Insertion) | 261d | 2010-04-06 A | 2011-04-25 A | 195212045 FS-125d | 100% |  | 2010-04-06 | 2011-04-22 |  |  |  | PROCUREMENT>$50K 69 NO ESCALATION | 6,363 | 0 | 6363 | 636300 | 100 | 6363 |  | 0 | CHUDAKOV | 1 | 1 | D | D | EUGENE C | 10-046 | 11-006 | 11-026 | 12-054F |  |  |  |  |  |  |  |
| 195212055 |  | Straw preparation Axial section 2 (P2 Straw Insertion) | 266d | 2010-04-06 A | 2011-04-30 A | 195212050 FS-125d | 100% |  | 2010-04-06 | 2011-04-29 |  |  |  | PROCUREMENT>$50K 69 NO ESCALATION | 8,280 | 0 | 8280 | 828000 | 100 | 8280 |  | 0 | CHUDAKOV | 1 | 1 | D | D | EUGENE C | 10-046 | 11-006 | 11-026 | 12-054F |  |  |  |  |  |  |  |
| 195212060 |  | Insert straws axial section 2 (P2 Straw Insertion) | 266d | 2010-04-06 A | 2011-04-30 A | 195212055 FS-125d | 100% |  | 2010-04-06 | 2011-04-29 |  |  |  | PROCUREMENT>$50K 69 NO ESCALATION | 8,280 | 0 | 8280 | 828000 | 100 | 8280 |  | 0 | CHUDAKOV | 1 | 1 | D | D | EUGENE C | 10-046 | 11-006 | 11-026 | 12-054F |  |  |  |  |  |  |  |
| 195212065 |  | Straw preparation stereo section 2-R-1 (P2 Straw Insertion) | 260d | 2010-04-06 A | 2011-04-21 A | 195212060 FS-146d | 100% |  |  |  |  |  |  | PROCUREMENT>$50K 69 NO ESCALATION | 4,733.5 | 0 | 4733.5 | 473350 | 100 | 4733.5 |  | 0 | CHUDAKOV | 1 | 1 | D | D | EUGENE C | 10-046 | 11-006 | 11-026 | 12-054F |  |  |  |  |  |  |  |
| 195212070 |  | Insert strwas stereo section 2-R-1 (P2 Straw Insertion) | 260d | 2010-04-06 A | 2011-04-21 A | 195212065 FS-166d | 100% |  |  |  |  |  |  | PROCUREMENT>$50K 69 NO ESCALATION | 4,733.5 | 0 | 4733.5 | 473350 | 100 | 4733.5 |  | 0 | CHUDAKOV | 1 | 1 | D | D | EUGENE C | 10-046 | 11-006 | 11-026 | 12-054F |  |  |  |  |  |  |  |
| 195212075 |  | Straw preparation stereo section 2-R-2 (P2 Straw Insertion) | 300d | 2010-04-06 A | 2011-06-18 A | 195212070 FS-166d | 100% |  | 2010-04-06 | 2011-06-17 |  |  |  | PROCUREMENT>$50K 69 NO ESCALATION | 5,117 | 0 | 5117 | 511700 | 100 | 5117 |  | 0 | CHUDAKOV | 1 | 1 | D | D | EUGENE C | 10-046 | 11-006 | 11-026 | 12-054F |  |  |  |  |  |  |  |
| 195212080 |  | Insert straws stereo section 2-R-2 (P2 Straw Insertion) | 298d | 2010-04-06 A | 2011-06-15 A | 195212075 FS-183d | 100% |  |  |  |  |  |  | PROCUREMENT>$50K 69 NO ESCALATION | 5,117 | 0 | 5117 | 511700 | 100 | 5117 |  | 0 | CHUDAKOV | 1 | 1 | D | D | EUGENE C | 10-046 | 11-006 | 11-026 | 12-054F |  |  |  |  |  |  |  |
| 195212085 |  | Straw preparation stereo section 2-L-1 (P2 Straw Insertion) | 295d | 2010-04-06 A | 2011-06-12 A | 195212080 FS-183d | 100% |  | 2010-04-06 | 2011-06-10 |  |  |  | PROCUREMENT>$50K 69 NO ESCALATION | 5,500 | 0 | 5500 | 550000 | 100 | 5500 |  | 0 | CHUDAKOV | 1 | 1 | D | D | EUGENE C | 10-046 | 11-006 | 11-026 | 12-054F |  |  |  |  |  |  |  |
| 195212090 |  | Insert straws stereo section 2-L-1 (P2 Straw Insertion) | 301d | 2010-04-06 A | 2011-06-20 A | 195212085 FS-203d | 100% |  |  |  |  |  |  | PROCUREMENT>$50K 69 NO ESCALATION | 5,500 | 0 | 5500 | 550000 | 100 | 5500 |  | 0 | CHUDAKOV | 1 | 1 | D | D | EUGENE C | 10-046 | 11-006 | 11-026 | 12-054F |  |  |  |  |  |  |  |
| 195212095 |  | Straw preparation stereo section 2-L-2 (P2 Straw Insertion) | 320d | 2010-04-06 A | 2011-07-18 A | 195212090 FS-203d | 100% |  |  |  |  |  |  | PROCUREMENT>$50K 69 NO ESCALATION | 5,883.5 | 0 | 5883.5 | 588350 | 100 | 5883.5 |  | 0 | CHUDAKOV | 1 | 1 | D | D | EUGENE C | 10-046 | 11-006 | 11-026 | 12-054F |  |  |  |  |  |  |  |
| 195212100 |  | Insert straws stereo section 2-L-2 (P2 Straw Insertion) | 320d | 2010-04-06 A | 2011-07-18 A | 195212095 FS-203d | 100% |  |  |  |  |  |  | PROCUREMENT>$50K 69 NO ESCALATION | 5,883.5 | 0 | 5883.5 | 588350 | 100 | 5883.5 |  | 0 | CHUDAKOV | 1 | 1 | D | D | EUGENE C | 10-046 | 11-006 | 11-026 | 12-054F |  |  |  |  |  |  |  |
| 195212105 |  | Straw preparation Axial Section 3-1 (P2 Straw Insertion) | 351d | 2010-04-06 A | 2011-08-30 A | 195212100 FS-203d | 100% |  |  |  |  |  |  | PROCUREMENT>$50K 69 NO ESCALATION | 6,395 | 0 | 6395 | 639500 | 100 | 6395 |  | 0 | CHUDAKOV | 1 | 1 | D | D | EUGENE C | 10-046 | 11-006 | 11-026 | 12-054F |  |  |  |  |  |  |  |
| 195212110 |  | Insert straws axial section 3-1 (P2 Straw Insertion) | 351d | 2010-04-06 A | 2011-08-30 A | 195212105 FS-222d | 100% |  |  |  |  |  |  | PROCUREMENT>$50K 69 NO ESCALATION | 6,395 | 0 | 6395 | 639500 | 100 | 6395 |  | 0 | CHUDAKOV | 1 | 1 | D | D | EUGENE C | 10-046 | 11-006 | 11-026 | 12-054F |  |  |  |  |  |  |  |
| 195212115 |  | Straw preparation Axial Section 3-2 (P2 Straw Insertion) | 364d | 2010-04-06 A | 2011-09-19 A | 195212110 FS-222d | 100% |  |  |  |  |  |  | PROCUREMENT>$50K 69 NO ESCALATION | 6,778.5 | 0 | 6778.5 | 677850 | 100 | 6778.5 |  | 0 | CHUDAKOV | 1 | 1 | D | D | EUGENE C | 10-046 | 11-006 | 11-026 | 12-054F |  |  |  |  |  |  |  |
| 195212120 |  | Insert Straws Axial Section 3-2 (P2 Straw Insertion) | 364d | 2010-04-06 A | 2011-09-19 A | 195212115 FS-245d | 100% |  |  |  |  |  |  | PROCUREMENT>$50K 69 NO ESCALATION | 6,778.5 | 0 | 6778.5 | 677850 | 100 | 6778.5 |  | 0 | CHUDAKOV | 1 | 1 | D | D | EUGENE C | 10-046 | 11-006 | 11-026 | 12-054F |  |  |  |  |  |  |  |
| 195212125 |  | Install Gas lines in CDC volume (P3 Shell Installation) | 364d | 2010-04-06 A | 2011-09-19 A | 195212120 FS-245d | 100% |  |  |  |  |  |  | PROCUREMENT>$50K 69 NO ESCALATION | 2,768.7 | 0 | 2768.7 | 276870 | 100 | 2768.7 |  | 0 | CHUDAKOV | 1 | 1 | D | D | EUGENE C | 10-046 | 11-006 | 11-026 | 12-054F |  |  |  |  |  |  |  |
| 195212130 |  | Install sensors in CDC Volume (P3 Shell Installation) | 384d | 2010-04-06 A | 2011-10-17 A | 195212125 FS-266d | 100% |  |  |  |  |  |  | PROCUREMENT>$50K 69 NO ESCALATION | 1,426.3 | 0 | 1426.3 | 142630 | 100 | 1426.3 |  | 0 | CHUDAKOV | 1 | 1 | D | D | EUGENE C | 10-046 | 11-006 | 11-026 | 12-054F |  |  |  |  |  |  |  |
| 195212135 |  | Installation outer shell (P3 Shell Installation) | 384d | 2010-04-06 A | 2011-10-17 A | 195212130 FS-266d | 100% |  |  |  |  |  |  | PROCUREMENT>$50K 69 NO ESCALATION | 10,586 | 0 | 10586 | 1058600 | 100 | 10586 |  | 0 | CHUDAKOV | 1 | 1 | D | D | EUGENE C | 10-046 | 11-006 | 11-026 | 12-054F |  |  |  |  |  |  |  |
| 195212140 |  | String 1st axial section (P3 Chamber stringing) | 302d | 2010-04-06 A | 2011-06-21 A | 195212135 FS-287d | 100% |  |  |  |  |  |  | PROCUREMENT>$50K 69 NO ESCALATION | 6,335 | 0 | 6335 | 633500 | 100 | 6335 |  | 0 | CHUDAKOV | 1 | 1 | D | D | EUGENE C | 10-046 | 11-006 | 11-026 | 12-054F |  |  |  |  |  |  |  |
| 195212145 |  | String 1st stereo section (P3 Chamber stringing) | 427d | 2010-04-06 A | 2011-12-19 A | 195212140 FS-287d | 100% |  |  |  |  |  |  | PROCUREMENT>$50K 69 NO ESCALATION | 9,403 | 0 | 9403 | 940300 | 100 | 9403 |  | 0 | CHUDAKOV | 1 | 1 | D | D | EUGENE C | 10-046 | 11-006 | 11-026 | 12-054F |  |  |  |  |  |  |  |
| 195212150 |  | String 2nd stereo section (P3 Chamber stringing) | 427d | 2010-04-06 A | 2011-12-19 A | 195212145 FS-309d | 100% |  |  |  |  |  |  | PROCUREMENT>$50K 69 NO ESCALATION | 12,726 | 0 | 12726 | 1272600 | 100 | 12726 |  | 0 | CHUDAKOV | 1 | 1 | D | D | EUGENE C | 10-046 | 11-006 | 11-026 | 12-054F |  |  |  |  |  |  |  |
| 195212155 |  | String 2nd axial section (P3 Chamber stringing) | 384d | 2010-04-06 A | 2011-10-17 A | 195212150 FS-287d | 100% |  |  |  |  |  |  | PROCUREMENT>$50K 69 NO ESCALATION | 16,560 | 0 | 16560 | 1656000 | 100 | 16560 |  | 0 | CHUDAKOV | 1 | 1 | D | D | EUGENE C | 10-046 | 11-006 | 11-026 | 12-054F |  |  |  |  |  |  |  |
| 195212160 |  | String 3rd stereo section (inner) (P3 Chamber stringing) | 460d | 2010-04-06 A | 2012-02-13 A | 195212155 FS-352d | 100% |  |  |  |  |  |  | PROCUREMENT>$50K 69 NO ESCALATION | 9,467 | 0 | 9467 | 946700 | 100 | 9467 |  | 0 | CHUDAKOV | 1 | 1 | D | D | EUGENE C | 10-046 | 11-006 | 11-026 | 12-054F |  |  |  |  |  |  |  |
| 195212165 |  | String 3rd stereo section (outer) (P3 Chamber stringing) | 460d | 2010-04-06 A | 2012-02-13 A | 195212160 FS-352d | 100% |  |  |  |  |  |  | PROCUREMENT>$50K 69 NO ESCALATION | 10,234 | 0 | 10234 | 1023400 | 100 | 10234 |  | 0 | CHUDAKOV | 1 | 1 | D | D | EUGENE C | 10-046 | 11-006 | 11-026 | 12-054F |  |  |  |  |  |  |  |
| 195212170 |  | String 4th stereo section (inner) (P3 Chamber stringing) | 464d | 2010-04-06 A | 2012-02-20 A | 195212165 FS-373d | 100% |  | 2010-04-06 | 2012-02-17 |  |  |  | PROCUREMENT>$50K 69 NO ESCALATION | 11,000 | 0 | 11000 | 1100000 | 100 | 11000 |  | 0 | CHUDAKOV | 1 | 1 | D | D | EUGENE C | 10-046 | 11-006 | 11-026 | 12-054F |  |  |  |  |  |  |  |
| 195212175 |  | String 4th stereo section (outer) (P3 Chamber stringing) | 464d | 2010-04-06 A | 2012-02-20 A | 195212170 FS-394d | 100% |  | 2010-04-06 | 2012-02-17 |  |  |  | PROCUREMENT>$50K 69 NO ESCALATION | 11,767 | 0 | 11767 | 1176700 | 100 | 11767 |  | 0 | CHUDAKOV | 1 | 1 | D | D | EUGENE C | 10-046 | 11-006 | 11-026 | 12-054F |  |  |  |  |  |  |  |
| 195212180 |  | String 3rd axial section (inner) (P3 Chamber stringing) | 414d | 2010-04-06 A | 2011-11-30 A | 195212175 FS-414d | 100% |  |  |  |  |  |  | PROCUREMENT>$50K 69 NO ESCALATION | 12,790 | 0 | 12790 | 1279000 | 100 | 12790 |  | 0 | CHUDAKOV | 1 | 1 | D | D | EUGENE C | 10-046 | 11-006 | 11-026 | 12-054F |  |  |  |  |  |  |  |
| 195212185 |  | String 3rd axial section (outer) (P3 Chamber stringing) | 414d | 2010-04-06 A | 2011-11-30 A | 195212180 FS-431d | 100% |  |  |  |  |  |  | PROCUREMENT>$50K 69 NO ESCALATION | 13,557 | 0 | 13557 | 1355700 | 100 | 13557 |  | 0 | CHUDAKOV | 1 | 1 | D | D | EUGENE C | 10-046 | 11-006 | 11-026 | 12-054F |  |  |  |  |  |  |  |
| 195212190 |  | Electronics installation 1st axial section (P4 Chamber instrumentation) | 524d | 2010-04-06 A | 2012-05-14 A | 195212185 FS-451d | 100% |  |  |  |  |  |  | PROCUREMENT>$50K 69 NO ESCALATION | 4,162 | 0 | 4162 | 416200 | 100 | 4162 |  | 0 | CHUDAKOV | 1 | 1 | D | D | EUGENE C | 10-046 | 11-006 | 11-026 | 12-054F |  |  |  |  |  |  |  |
| 195212195 |  | Electronics installation 1st stereo section (P4 Chamber instrumentation) | 542d | 2010-04-06 A | 2012-06-11 A | 195212190 FS-451d | 100% |  |  |  |  |  |  | PROCUREMENT>$50K 69 NO ESCALATION | 6,143 | 0 | 6143 | 614300 | 100 | 6143 |  | 0 | CHUDAKOV | 1 | 1 | D | D | EUGENE C | 10-046 | 11-006 | 11-026 | 12-054F |  |  |  |  |  |  |  |
| 195212200 |  | Electronics installation 2nd stereo section (P4 Chamber instrumentation) | 542d | 2010-04-06 A | 2012-06-11 A | 195212195 FS-471d | 100% |  |  |  |  |  |  | PROCUREMENT>$50K 69 NO ESCALATION | 8,290 | 0 | 8290 | 829000 | 100 | 8290 |  | 0 | CHUDAKOV | 1 | 1 | D | D | EUGENE C | 10-046 | 11-006 | 11-026 | 12-054F |  |  |  |  |  |  |  |
| 195212205 |  | Electronics installation 2nd axial section (P4 Chamber instrumentation) | 567d | 2010-04-06 A | 2012-07-16 A | 195212200 FS-471d | 100% |  |  |  |  |  |  | PROCUREMENT>$50K 69 NO ESCALATION | 10,766 | 0 | 10766 | 1076600 | 100 | 10766 |  | 0 | CHUDAKOV | 1 | 1 | D | D | EUGENE C | 10-046 | 11-006 | 11-026 | 12-054F |  |  |  |  |  |  |  |
| 195212210 |  | Electronics installation 3rd stereo section (inner) (P4 Chamber instrumentation) | 567d | 2010-04-06 A | 2012-07-16 A | 195212205 FS-493d | 100% |  |  |  |  |  |  | PROCUREMENT>$50K 69 NO ESCALATION | 6,185 | 0 | 6185 | 618500 | 100 | 6185 |  | 0 | CHUDAKOV | 1 | 1 | D | D | EUGENE C | 10-046 | 11-006 | 11-026 | 12-054F |  |  |  |  |  |  |  |
| 195212215 |  | Electronics installation 3rd stereo section (outer) (P4 Chamber instrumentation) | 567d | 2010-04-06 A | 2012-07-16 A | 195212210 FS-493d | 100% |  |  |  |  |  |  | PROCUREMENT>$50K 69 NO ESCALATION | 6,680 | 0 | 6680 | 668000 | 100 | 6680 |  | 0 | CHUDAKOV | 1 | 1 | D | D | EUGENE C | 10-046 | 11-006 | 11-026 | 12-054F |  |  |  |  |  |  |  |
| 195212220 |  | Electronics installation 4th stereo section (inner) (P4 Chamber instrumentation) | 587d | 2010-04-06 A | 2012-08-13 A | 195212215 FS-514d | 100% |  |  |  |  |  |  | PROCUREMENT>$50K 69 NO ESCALATION | 7,175 | 0 | 7175 | 717500 | 100 | 7175 |  | 0 | CHUDAKOV | 1 | 1 | D | D | EUGENE C | 10-046 | 11-006 | 11-026 | 12-054F |  |  |  |  |  |  |  |
| 195212225 |  | Electronics installation 4th stereo section (outer) (P4 Chamber instrumentation) | 631d | 2010-04-06 A | 2012-10-15 A | 195212220 FS-514d | 100% |  |  |  |  |  |  | PROCUREMENT>$50K 69 NO ESCALATION | 7,671 | 0 | 7671 | 767100 | 100 | 7671 |  | 0 | CHUDAKOV | 1 | 1 | D | D | EUGENE C | 10-046 | 11-006 | 11-026 | 12-054F |  |  |  |  |  |  |  |
| 195212230 |  | Electronics installation 3rd axial section (inner) (P4 Chamber instrumentation) | 636d | 2010-04-06 A | 2012-10-22 A | 195212225 FS-536d | 100% |  |  |  |  |  |  | PROCUREMENT>$50K 69 NO ESCALATION | 8,331 | 0 | 8331 | 833100 | 100 | 8331 |  | 0 | CHUDAKOV | 1 | 1 | D | D | EUGENE C | 10-046 | 11-006 | 11-026 | 12-054F |  |  |  |  |  |  |  |
| 195212235 |  | Electronics installation 3rd axial section (outer) (P4 Chamber instrumentation) | 651d | 2010-04-06 A | 2012-11-12 A | 195212230 FS-536d | 100% |  |  |  |  |  |  | PROCUREMENT>$50K 69 NO ESCALATION | 8,826 | 0 | 8826 | 882600 | 100 | 8826 |  | 0 | CHUDAKOV | 1 | 1 | D | D | EUGENE C | 10-046 | 11-006 | 11-026 | 12-054F |  |  |  |  |  |  |  |
| 195212240 |  | Close up gas upstream and downstream gas plenum (P5 Chamber operational tests) | 751d | 2010-04-06 A | 2013-03-11 A | 195212235 FS-556d | 100% |  | 2010-04-06 | 2013-04-15 |  |  |  | PROCUREMENT>$50K 69 NO ESCALATION | 10,086 | 0 | 10086 | 1008600 | 100 | 10086 |  | 0 | CHUDAKOV | 1 | 1 | D | D | EUGENE C | 10-046 | 11-006 | 11-026 | 12-054F |  |  |  |  |  |  |  |
| 195212245 |  | Gas leak tests (P5 Chamber operational tests) | 761d | 2010-04-06 A | 2013-03-11 A | 195212240 FS-578d | 100% |  | 2010-04-06 | 2013-04-29 |  |  |  | PROCUREMENT>$50K 69 NO ESCALATION | 16,477 | 0 | 16477 | 1647700 | 100 | 16477 |  | 0 | CHUDAKOV | 1 | 1 | D | D | EUGENE C | 10-046 | 11-006 | 11-026 | 12-054F |  |  |  |  |  |  |  |
| 195212250 |  | HV tests (P5 Chamber operational tests) | 806d | 2010-04-06 A | 2013-05-13 A | 195212245 FS-601d | 100% |  | 2010-04-06 | 2013-07-02 |  |  |  | PROCUREMENT>$50K 69 NO ESCALATION | 15,768 | 0 | 15768 | 1576800 | 100 | 15768 |  | 0 | CHUDAKOV | 1 | 1 | D | D | EUGENE C | 10-046 | 11-006 | 11-026 | 12-054F |  |  |  |  |  |  |  |
| 195212255 |  | Operations Test (P5 Chamber operational tests) | 802d | 2010-04-06 A | 2013-08-30 A | 195212250 FS-643d | 100% |  | 2010-04-06 | 2013-06-26 |  |  |  | PROCUREMENT>$50K 69 NO ESCALATION | 10,446 | 0 | 10446 | 1044600 | 100 | 10446 |  | 4178.4 | CHUDAKOV | 1 | 1 | D | D | EUGENE C | 10-046 | 11-006 | 11-026 | 12-054F |  |  |  |  |  |  |  |
| 195212260 |  | Phase 7 Chamber shipping | 802d | 2010-04-06 A | 2013-08-30 A | 195212255 FS-719d | 100% |  | 2010-04-06 | 2013-06-26 |  |  |  | PROCUREMENT>$50K 69 NO ESCALATION | 5,000 | 0 | 5000 | 500000 | 100 | 5000 |  | 5000 | CHUDAKOV | 1 | 1 | D | D | EUGENE C | 10-046 | 11-006 | 11-026 | 12-054F |  |  |  |  |  |  |  |
| 195212265 |  | Re-Baseline Actuals Adjustment | 1d | 2013-08-30 A | 2013-08-30 A |  | 100% |  | 2013-09-03 | 2013-09-03 |  |  |  | PROCUREMENT>$50K 69 NO ESCALATION | -61,782.34 |  |  |  | 100 |  | ADJ |  |  |  |  |  |  |  |  |  |  |  |  |  |  |  |  |  |  |
| 295212255 |  | Operations Test (P5 Chamber operational tests) | 43d | 2013-09-03 A | 2013-12-05 | 9-130M FS+228d | 20% | 23d | 2013-10-01 | 2013-12-02 | 102d | 20d | 8/5 M-F w/JLAB Holidays ReBaseline | PROCUREMENT>$50K 69 NO ESCALATION | 56,782.34 | 45425.872 | 11356.468 | 1135646.8 | 100 | 0 |  |  | CHUDAKOV | 1 | 1 | D | D | EUGENE C | 10-046 | 11-006 | 11-026 | 12-054F | 295212255 | 11356.468 | 13-007F | OB | 13-015 | PR | OB |
| 295212260 |  | Phase 7 Chamber shipping | 43d | 2013-09-03 A | 2013-10-21 A | 295212255 FS-43d | 100% |  | 2013-10-01 | 2013-12-02 |  |  | 8/5 M-F w/JLAB Holidays ReBaseline | PROCUREMENT>$50K 69 NO ESCALATION | 5,000 | 0 | 5000 | 500000 | 100 | 5000 |  |  | CHUDAKOV | 1 | 1 | D | D | EUGENE C | 10-046 | 11-006 | 11-026 | 12-054F | 295212260 |  | 13-007F | OB | 13-015 | PR | OB |

| ID | WBS | Activity | Duration | Start | Finish | Predecessors | Complete | Planned start | Planned finish | Resources | Cost | LOE Divider | LOE Multiplier | Remaining Material Cost Based on % Compl | Claimed Material Cost Based on % Complet | Initial Claimed Material Calc | Claimed Material Divider | Calculated Remaining Total Cost | MONTHLY EV COST | RESP - Responsibility | STRT%COMP for CM EVM | FNSH%COMP for CM EVM | HALL D Related Milestones | Advance Purchase Plan > 500K | EVMS Reporting Codes | CAM RESPONSIBLE | 12 GEV MAJOR PROCUREMENT CATAGORY | CR 09-043 | CR 10-001 | CR 10-034 | CR 11-006 | CR 11-026 | CR 12-021 | CR 12-054 | CR 09-014 | CR 08-016 | 12 GeV 1st level Critical Path | CR 09-027 | CR 09-027 Repair | CIVIL CRITICAL MILESTONES | CR 07-024 | CR 09-004 | CR 09-052 | LOE % Pre Calc | LOE % | Activities with Steps |
| --- | --- | --- | --- | --- | --- | --- | --- | --- | --- | --- | --- | --- | --- | --- | --- | --- | --- | --- | --- | --- | --- | --- | --- | --- | --- | --- | --- | --- | --- | --- | --- | --- | --- | --- | --- | --- | --- | --- | --- | --- | --- | --- | --- | --- | --- | --- |
|  | 2 | **1.9.5.2.2 HALL D CALORIMETRY** |  | 2010-03-01 | 2013-09-23 |  |  |  |  |  |  |  |  |  |  |  |  |  |  |  |  |  |  |  |  |  |  |  |  |  |  |  |  |  |  |  |  |  |  |  |  |  |  |  |  |  |
|  | 1 | **1.9.5.2.2.1 HALL D BARREL CALORIMETER** |  | 2010-03-02 | 2013-08-30 |  |  |  |  |  |  |  |  |  |  |  |  |  |  |  |  |  |  |  |  |  |  |  |  |  |  |  |  |  |  |  |  |  |  |  |  |  |  |  |  |  |
| 195221015 |  | Bcal Module Construction Manager Phase 2 (LOE) | 209d | 2010-03-02 A | 2010-12-31 A | 15221195 | 100% |  |  | PROCUREMENT>$50K 69 NO ESCALATION; PROCUREMENT<$50K 60 NO ESCALATION | 81,180 | 100 | 100 | 0 | 81180 | 8118000 | 100 | 0 | 81180 | CHUDAKOV | 1 | 1 | D | APP | E | EUGENE C | 5221B | 09-043 | 10-001A | 10-034 | 11-006 | 11-026 | 12-021F | 12-054F |  |  |  |  |  |  |  |  |  |  |  |  |
| 195221030 |  | Module #9 Matrix Fabrication | 60d | 2010-03-02 A | 2010-05-24 A | 15221050, 9-100M FS+98d | 100% |  |  | PROCUREMENT>$50K 69 NO ESCALATION | 12,842 |  |  | 0 | 12842 | 1284200 | 100 | 0 | 12842 | CHUDAKOV | 1 | 1 | D | APP | P | EUGENE C | 5221B | 09-043 | 10-001A | 10-034 | 11-006 | 11-026 | 12-021F | 12-054F | 09-014 |  |  |  |  |  |  |  |  |  |  |  |
| 195221035 |  | Module #9 Machining and Shipping | 114d | 2010-03-02 A | 2010-08-10 A | 9-100M FS+98d | 100% |  |  | PROCUREMENT>$50K 69 NO ESCALATION | 4,607 |  |  | 0 | 4607 | 460700 | 100 | 0 | 4607 | CHUDAKOV | 1 | 1 | D | APP | P | EUGENE C | 5221B | 09-043 | 10-001A | 10-034 | 11-006 | 11-026 | 12-021F | 12-054F |  |  |  |  |  |  |  |  |  |  |  |  |
| 195221040 |  | Module #10 Matrix Fabrication | 60d | 2010-03-02 A | 2010-05-24 A | 9-100M FS+98d | 100% |  |  | PROCUREMENT>$50K 69 NO ESCALATION | 12,842 |  |  | 0 | 12842 | 1284200 | 100 | 0 | 12842 | CHUDAKOV | 1 | 1 | D | APP | P | EUGENE C | 5221B | 09-043 | 10-001A | 10-034 | 11-006 | 11-026 | 12-021F | 12-054F |  |  |  |  |  |  |  |  |  |  |  |  |
| 195221045 |  | Module #10 Machining and Shipping | 114d | 2010-03-02 A | 2010-08-10 A | 9-100M FS+98d | 100% |  |  | PROCUREMENT>$50K 69 NO ESCALATION | 4,607 |  |  | 0 | 4607 | 460700 | 100 | 0 | 4607 | CHUDAKOV | 1 | 1 | D | APP | P | EUGENE C | 5221B | 09-043 | 10-001A | 10-034 | 11-006 | 11-026 | 12-021F | 12-054F |  |  |  |  |  |  |  |  |  |  |  |  |
| 195221050 |  | Module #11 Matrix Fabrication | 70d | 2010-03-02 A | 2010-06-08 A | 9-100M FS+98d | 100% |  |  | PROCUREMENT>$50K 69 NO ESCALATION | 12,842 |  |  | 0 | 12842 | 1284200 | 100 | 0 | 12842 | CHUDAKOV | 1 | 1 | D | APP | P | EUGENE C | 5221B | 09-043 | 10-001A | 10-034 | 11-006 | 11-026 | 12-021F | 12-054F |  |  |  |  |  |  |  |  |  |  |  |  |
| 195221055 |  | Module #11 Machining and Shipping | 114d | 2010-03-02 A | 2010-08-10 A | 9-100M FS+98d | 100% |  |  | PROCUREMENT>$50K 69 NO ESCALATION | 4,607 |  |  | 0 | 4607 | 460700 | 100 | 0 | 4607 | CHUDAKOV | 1 | 1 | D | APP | P | EUGENE C | 5221B | 09-043 | 10-001A | 10-034 | 11-006 | 11-026 | 12-021F | 12-054F | 09-014 |  |  |  |  |  |  |  |  |  |  |  |
| 195221060 |  | Module #12 Matrix Fabrication | 70d | 2010-03-02 A | 2010-06-08 A | 9-100M FS+98d | 100% |  |  | PROCUREMENT>$50K 69 NO ESCALATION | 12,842 |  |  | 0 | 12842 | 1284200 | 100 | 0 | 12842 | CHUDAKOV | 1 | 1 | D | APP | P | EUGENE C | 5221B | 09-043 | 10-001A | 10-034 | 11-006 | 11-026 | 12-021F | 12-054F | 09-014 |  |  |  |  |  |  |  |  |  |  |  |
| 195221065 |  | Module #12 Machining and Shipping | 114d | 2010-03-02 A | 2010-08-10 A | 9-100M FS+98d | 100% |  |  | PROCUREMENT>$50K 69 NO ESCALATION | 4,607 |  |  | 0 | 4607 | 460700 | 100 | 0 | 4607 | CHUDAKOV | 1 | 1 | D | APP | P | EUGENE C | 5221B | 09-043 | 10-001A | 10-034 | 11-006 | 11-026 | 12-021F | 12-054F | 09-014 |  |  |  |  |  |  |  |  |  |  |  |
| 195221070 |  | Module #13 Matrix Fabrication | 103d | 2010-03-02 A | 2010-07-26 A | 9-100M FS+98d | 100% |  |  | PROCUREMENT>$50K 69 NO ESCALATION | 12,842 |  |  | 0 | 12842 | 1284200 | 100 | 0 | 12842 | CHUDAKOV | 1 | 1 | D | APP | P | EUGENE C | 5221B | 09-043 | 10-001A | 10-034 | 11-006 | 11-026 | 12-021F | 12-054F | 09-014 | 08-016 |  |  |  |  |  |  |  |  |  |  |
| 195221075 |  | Module #13 Machining and Shipping | 142d | 2010-03-02 A | 2010-09-20 A | 9-100M FS+98d | 100% |  |  | PROCUREMENT>$50K 69 NO ESCALATION | 4,607 |  |  | 0 | 4607 | 460700 | 100 | 0 | 4607 | CHUDAKOV | 1 | 1 | D | APP | P | EUGENE C | 5221B | 09-043 | 10-001A | 10-034 | 11-006 | 11-026 | 12-021F | 12-054F | 09-014 |  |  |  |  |  |  |  |  |  |  |  |
| 195221080 |  | Module #14 Matrix Fabrication | 103d | 2010-03-02 A | 2010-07-26 A | 9-100M FS+98d | 100% |  |  | PROCUREMENT>$50K 69 NO ESCALATION | 12,842 |  |  | 0 | 12842 | 1284200 | 100 | 0 | 12842 | CHUDAKOV | 1 | 1 | D | APP | P | EUGENE C | 5221B | 09-043 | 10-001A | 10-034 | 11-006 | 11-026 | 12-021F | 12-054F | 09-014 | 08-016 |  |  |  |  |  |  |  |  |  |  |
| 195221085 |  | Module #14 Machining and Shipping | 142d | 2010-03-02 A | 2010-09-20 A | 9-100M FS+98d | 100% |  |  | PROCUREMENT>$50K 69 NO ESCALATION | 4,607 |  |  | 0 | 4607 | 460700 | 100 | 0 | 4607 | CHUDAKOV | 1 | 1 | D | APP | P | EUGENE C | 5221B | 09-043 | 10-001A | 10-034 | 11-006 | 11-026 | 12-021F | 12-054F | 09-014 |  |  |  |  |  |  |  |  |  |  |  |
| 195221090 |  | Module #15 Matrix Fabrication | 123d | 2010-03-02 A | 2010-08-23 A | 9-100M FS+98d | 100% |  |  | PROCUREMENT>$50K 69 NO ESCALATION | 12,842 |  |  | 0 | 12842 | 1284200 | 100 | 0 | 12842 | CHUDAKOV | 1 | 1 | D | APP | P | EUGENE C | 5221B | 09-043 | 10-001A | 10-034 | 11-006 | 11-026 | 12-021F | 12-054F | 09-014 |  |  |  |  |  |  |  |  |  |  |  |
| 195221095 |  | Module #15 Machining and Shipping | 142d | 2010-03-02 A | 2010-09-20 A | 9-100M FS+98d | 100% |  |  | PROCUREMENT>$50K 69 NO ESCALATION | 4,607 |  |  | 0 | 4607 | 460700 | 100 | 0 | 4607 | CHUDAKOV | 1 | 1 | D | APP | P | EUGENE C | 5221B | 09-043 | 10-001A | 10-034 | 11-006 | 11-026 | 12-021F | 12-054F | 09-014 |  |  |  |  |  |  |  |  |  |  |  |
| 195221100 |  | Module #16 Matrix Fabrication | 123d | 2010-03-02 A | 2010-08-23 A | 9-100M FS+98d | 100% |  |  | PROCUREMENT>$50K 69 NO ESCALATION | 12,842 |  |  | 0 | 12842 | 1284200 | 100 | 0 | 12842 | CHUDAKOV | 1 | 1 | D | APP | P | EUGENE C | 5221B | 09-043 | 10-001A | 10-034 | 11-006 | 11-026 | 12-021F | 12-054F | 09-014 |  |  |  |  |  |  |  |  |  |  |  |
| 195221105 |  | Module #16 Machining and Shipping | 142d | 2010-03-02 A | 2010-09-20 A | 9-100M FS+98d | 100% |  |  | PROCUREMENT>$50K 69 NO ESCALATION | 4,607 |  |  | 0 | 4607 | 460700 | 100 | 0 | 4607 | CHUDAKOV | 1 | 1 | D | APP | P | EUGENE C | 5221B | 09-043 | 10-001A | 10-034 | 11-006 | 11-026 | 12-021F | 12-054F | 09-014 |  |  |  |  |  |  |  |  |  |  |  |
| 195221110 |  | Module #17 Matrix Fabrication | 128d | 2010-03-02 A | 2010-08-30 A | 9-100M FS+98d | 100% |  |  | PROCUREMENT>$50K 69 NO ESCALATION | 12,842 |  |  | 0 | 12842 | 1284200 | 100 | 0 | 12842 | CHUDAKOV | 1 | 1 | D | APP | P | EUGENE C | 5221B | 09-043 | 10-001A | 10-034 | 11-006 | 11-026 | 12-021F | 12-054F | 09-014 |  |  |  |  |  |  |  |  |  |  |  |
| 195221115 |  | Module #17 Machining and Shipping | 198d | 2010-03-02 A | 2010-12-09 A | 9-100M FS+98d | 100% |  |  | PROCUREMENT>$50K 69 NO ESCALATION | 4,607 |  |  | 0 | 4607 | 460700 | 100 | 0 | 4607 | CHUDAKOV | 1 | 1 | D | APP | P | EUGENE C | 5221B | 09-043 | 10-001A | 10-034 | 11-006 | 11-026 | 12-021F | 12-054F |  |  |  |  |  |  |  |  |  |  |  |  |
| 195221120 |  | Module #18 Matrix Fabrication | 129d | 2010-03-02 A | 2010-08-31 A | 9-100M FS+98d | 100% |  |  | PROCUREMENT>$50K 69 NO ESCALATION | 12,842 |  |  | 0 | 12842 | 1284200 | 100 | 0 | 12842 | CHUDAKOV | 1 | 1 | D | APP | P | EUGENE C | 5221B | 09-043 | 10-001A | 10-034 | 11-006 | 11-026 | 12-021F | 12-054F | 09-014 |  |  |  |  |  |  |  |  |  |  |  |
| 195221125 |  | Module #18 Machining and Shipping | 198d | 2010-03-02 A | 2010-12-09 A | 9-100M FS+98d | 100% |  |  | PROCUREMENT>$50K 69 NO ESCALATION | 4,607 |  |  | 0 | 4607 | 460700 | 100 | 0 | 4607 | CHUDAKOV | 1 | 1 | D | APP | P | EUGENE C | 5221B | 09-043 | 10-001A | 10-034 | 11-006 | 11-026 | 12-021F | 12-054F |  |  |  |  |  |  |  |  |  |  |  |  |
| 195221130 |  | Module #19 Matrix Fabrication | 142d | 2010-03-02 A | 2010-09-20 A | 9-100M FS+98d | 100% |  |  | PROCUREMENT>$50K 69 NO ESCALATION | 12,842 |  |  | 0 | 12842 | 1284200 | 100 | 0 | 12842 | CHUDAKOV | 1 | 1 | D | APP | P | EUGENE C | 5221B | 09-043 | 10-001A | 10-034 | 11-006 | 11-026 | 12-021F | 12-054F |  |  |  |  |  |  |  |  |  |  |  |  |
| 195221135 |  | Module #19 Machining and Shipping | 207d | 2010-03-02 A | 2010-12-29 A | 9-100M FS+98d | 100% |  |  | PROCUREMENT>$50K 69 NO ESCALATION | 4,607 |  |  | 0 | 4607 | 460700 | 100 | 0 | 4607 | CHUDAKOV | 1 | 1 | D | APP | P | EUGENE C | 5221B | 09-043 | 10-001A | 10-034 | 11-006 | 11-026 | 12-021F | 12-054F |  |  |  |  |  |  |  |  |  |  |  |  |
| 195221140 |  | Module #20 Matrix Fabrication | 142d | 2010-03-02 A | 2010-09-20 A | 9-100M FS+98d | 100% |  |  | PROCUREMENT>$50K 69 NO ESCALATION | 12,842 |  |  | 0 | 12842 | 1284200 | 100 | 0 | 12842 | CHUDAKOV | 1 | 1 | D | APP | P | EUGENE C | 5221B | 09-043 | 10-001A | 10-034 | 11-006 | 11-026 | 12-021F | 12-054F |  |  |  |  |  |  |  |  |  |  |  |  |
| 195221145 |  | Module #20 Machining and Shipping | 198d | 2010-03-02 A | 2010-12-09 A | 9-100M FS+98d | 100% |  |  | PROCUREMENT>$50K 69 NO ESCALATION | 4,607 |  |  | 0 | 4607 | 460700 | 100 | 0 | 4607 | CHUDAKOV | 1 | 1 | D | APP | P | EUGENE C | 5221B | 09-043 | 10-001A | 10-034 | 11-006 | 11-026 | 12-021F | 12-054F |  |  | 1 |  |  |  |  |  |  |  |  |  |
| 195221150 |  | Module #21 Matrix Fabrication | 167d | 2010-03-02 A | 2010-10-25 A | 9-100M FS+98d | 100% |  |  | PROCUREMENT>$50K 69 NO ESCALATION | 12,842 |  |  | 0 | 12842 | 1284200 | 100 | 0 | 12842 | CHUDAKOV | 1 | 1 | D | APP | P | EUGENE C | 5221B | 09-043 | 10-001A | 10-034 | 11-006 | 11-026 | 12-021F | 12-054F | 09-014 |  |  |  |  |  |  |  |  |  |  |  |
| 195221155 |  | Module #21 Machining and Shipping | 203d | 2010-03-02 A | 2010-12-16 A | 9-100M FS+98d | 100% |  |  | PROCUREMENT>$50K 69 NO ESCALATION | 4,607 |  |  | 0 | 4607 | 460700 | 100 | 0 | 4607 | CHUDAKOV | 1 | 1 | D | APP | P | EUGENE C | 5221B | 09-043 | 10-001A | 10-034 | 11-006 | 11-026 | 12-021F | 12-054F |  |  | 1 | 09-027 | 09-027 |  |  |  |  |  |  |  |
| 195221160 |  | Module #22 Matrix Fabrication | 167d | 2010-03-02 A | 2010-10-25 A | 9-100M FS+98d | 100% |  |  | PROCUREMENT>$50K 69 NO ESCALATION | 12,842 |  |  | 0 | 12842 | 1284200 | 100 | 0 | 12842 | CHUDAKOV | 1 | 1 | D | APP | P | EUGENE C | 5221B | 09-043 | 10-001A | 10-034 | 11-006 | 11-026 | 12-021F | 12-054F |  |  | 1 | 09-027 | 09-027 |  |  |  |  |  |  |  |
| 195221165 |  | Module #22 Machining and Shipping | 204d | 2010-03-02 A | 2010-12-17 A | 9-100M FS+98d | 100% |  |  | PROCUREMENT>$50K 69 NO ESCALATION | 4,607 |  |  | 0 | 4607 | 460700 | 100 | 0 | 4607 | CHUDAKOV | 1 | 1 | D | APP | P | EUGENE C | 5221B | 09-043 | 10-001A | 10-034 | 11-006 | 11-026 | 12-021F | 12-054F |  |  | 1 | 09-027 | 09-027 |  |  |  |  |  |  |  |
| 195221170 |  | Module #23 Matrix Fabrication | 187d | 2010-03-02 A | 2010-11-22 A | 9-100M FS+98d | 100% |  |  | PROCUREMENT>$50K 69 NO ESCALATION | 12,842 |  |  | 0 | 12842 | 1284200 | 100 | 0 | 12842 | CHUDAKOV | 1 | 1 | D | APP | P | EUGENE C | 5221B | 09-043 | 10-001A | 10-034 | 11-006 | 11-026 | 12-021F | 12-054F |  |  | 1 |  |  |  |  |  |  |  |  |  |
| 195221175 |  | Module #23 Machining and Shipping | 204d | 2010-03-02 A | 2010-12-17 A | 9-100M FS+98d | 100% |  |  | PROCUREMENT>$50K 69 NO ESCALATION | 4,607 |  |  | 0 | 4607 | 460700 | 100 | 0 | 4607 | CHUDAKOV | 1 | 1 | D | APP | P | EUGENE C | 5221B | 09-043 | 10-001A | 10-034 | 11-006 | 11-026 | 12-021F | 12-054F |  |  | 1 | 09-027 | 09-027 |  |  |  |  |  |  |  |
| 195221180 |  | Module #24 Matrix Fabrication | 187d | 2010-03-02 A | 2010-11-22 A | 9-100M FS+98d | 100% |  |  | PROCUREMENT>$50K 69 NO ESCALATION | 12,842 |  |  | 0 | 12842 | 1284200 | 100 | 0 | 12842 | CHUDAKOV | 1 | 1 | D | APP | P | EUGENE C | 5221B | 09-043 | 10-001A | 10-034 | 11-006 | 11-026 | 12-021F | 12-054F |  |  | 1 |  |  |  |  |  |  |  |  |  |
| 195221185 |  | Module #24 Machining and Shipping | 223d | 2010-03-02 A | 2011-01-24 A | 9-100M FS+98d | 100% |  |  | PROCUREMENT>$50K 69 NO ESCALATION | 4,607 |  |  | 0 | 4607 | 460700 | 100 | 0 | 4607 | CHUDAKOV | 1 | 1 | D | APP | P | EUGENE C | 5221B | 09-043 | 10-001A | 10-034 | 11-006 | 11-026 | 12-021F | 12-054F |  |  | 1 | 09-027 | 09-027 |  |  |  |  |  |  |  |
| 195221000 |  | Proc SciFi Mods P-3 FY11 October Delivery | 17d | 2010-10-01 A | 2010-10-25 A | 15221018K | 100% |  |  | PROCUREMENT>$50K 69 NO ESCALATION; PROCUREMENT<$50K 60 NO ESCALATION | 104,886.31 |  |  | 0 | 104886.31 | 10488631 | 100 | 0 | 104886.31 | CHUDAKOV | 1 | 1 | D | APP | P | EUGENE C | 5221A |  |  | 10-034 | 11-006 | 11-026 | 12-021F | 12-054F |  |  | 1 |  |  | CVL | 07-024 | 09-004 | 09-052 |  |  |  |
| 195221001 |  | Proc SciFi Mods P-3 FY11 November Delivery | 41d | 2010-10-01 A | 2010-11-30 A | 195221000 FS-21d | 100% |  |  | PROCUREMENT<$50K 60 NO ESCALATION; PROCUREMENT>$50K 69 NO ESCALATION | 104,886.31 |  |  | 0 | 104886.31 | 10488631 | 100 | 0 | 104886.31 | CHUDAKOV | 1 | 1 | D | APP | P | EUGENE C | 5221A |  |  | 10-034 | 11-006 | 11-026 | 12-021F | 12-054F |  |  | 1 |  |  | CVL |  |  |  |  |  |  |
| 195221020 |  | Bcal Module Construction Manager Phase 3 (LOE) | 306d | 2010-10-01 A | 2011-12-30 A | 195221015 FS-40d | 100% |  |  | PROCUREMENT<$50K 60 NO ESCALATION; PROCUREMENT>$50K 69 NO ESCALATION | 95,832 | 100 | 100 | 0 | 95832 | 9583200 | 100 | 0 | 95832 | CHUDAKOV | 1 | 1 | D | APP | E | EUGENE C | 5221B | 09-043 | 10-001A | 10-034 | 11-006 | 11-026 | 12-021F | 12-054F |  |  |  |  |  |  |  |  |  | 6.88259109 | 93.1174089 | NB |
| 195221025 |  | Bcal Module Construction Manager Phase 4 (LOE) | 405d | 2010-10-01 A | 2012-05-22 A | 195221020 FS-295d | 100% |  |  | PROCUREMENT<$50K 60 NO ESCALATION | 36,828 | 100 | 100 | 0 | 36828 | 3682800 | 100 | 0 | 36828 | CHUDAKOV | 1 | 1 | D | APP | E | EUGENE C | 5221B | 09-043 | 10-001A | 10-034 | 11-006 | 11-026 | 12-021F | 12-054F |  |  |  |  |  |  |  |  |  | 16.16161616 | 83.83838383 | NB |
| 195221190 |  | Module #25 Matrix Fabrication | 54d | 2010-10-01 A | 2010-12-17 A | 9-110M | 100% |  |  | PROCUREMENT>$50K 69 NO ESCALATION | 12,842 |  |  | 0 | 12842 | 1284200 | 100 | 0 | 12842 | CHUDAKOV | 1 | 1 | D | APP | P | EUGENE C | 5221B | 09-043 | 10-001A | 10-034 | 11-006 | 11-026 | 12-021F | 12-054F | 09-014 |  |  |  |  |  |  |  |  |  |  |  |
| 195221195 |  | Module #25 Machining and Shipping | 137d | 2010-10-01 A | 2011-04-25 A | 9-110M | 100% |  |  | PROCUREMENT>$50K 69 NO ESCALATION | 4,607 |  |  | 0 | 4607 | 460700 | 100 | 0 | 4607 | CHUDAKOV | 1 | 1 | D | APP | P | EUGENE C | 5221B | 09-043 | 10-001A | 10-034 | 11-006 | 11-026 | 12-021F | 12-054F | 09-014 |  |  |  |  |  |  |  |  |  |  |  |
| 195221200 |  | Module #26 Matrix Fabrication | 56d | 2010-10-01 A | 2010-12-22 A | 9-110M | 100% | 2010-10-01 | 2010-12-21 | PROCUREMENT>$50K 69 NO ESCALATION | 12,842 |  |  | 0 | 12842 | 1284200 | 100 | 0 | 12842 | CHUDAKOV | 1 | 1 | D | APP | P | EUGENE C | 5221B | 09-043 | 10-001A | 10-034 | 11-006 | 11-026 | 12-021F | 12-054F | 09-014 |  |  |  |  |  |  |  |  |  |  |  |
| 195221205 |  | Module #26 Machining and Shipping | 137d | 2010-10-01 A | 2011-04-25 A | 9-110M | 100% |  |  | PROCUREMENT>$50K 69 NO ESCALATION | 4,607 |  |  | 0 | 4607 | 460700 | 100 | 0 | 4607 | CHUDAKOV | 1 | 1 | D | APP | P | EUGENE C | 5221B | 09-043 | 10-001A | 10-034 | 11-006 | 11-026 | 12-021F | 12-054F | 09-014 |  |  |  |  |  |  |  |  |  |  |  |
| 195221210 |  | Module #27 Matrix Fabrication | 68d | 2010-10-01 A | 2011-01-17 A | 9-110M | 100% | 2010-10-01 | 2011-01-14 | PROCUREMENT>$50K 69 NO ESCALATION | 12,842 |  |  | 0 | 12842 | 1284200 | 100 | 0 | 12842 | CHUDAKOV | 1 | 1 | D | APP | P | EUGENE C | 5221B | 09-043 | 10-001A | 10-034 | 11-006 | 11-026 | 12-021F | 12-054F | 09-014 |  |  |  |  |  |  |  |  |  |  |  |
| 195221215 |  | Module #27 Machining and Shipping | 137d | 2010-10-01 A | 2011-04-25 A | 9-110M | 100% |  |  | PROCUREMENT>$50K 69 NO ESCALATION | 4,607 |  |  | 0 | 4607 | 460700 | 100 | 0 | 4607 | CHUDAKOV | 1 | 1 | D | APP | P | EUGENE C | 5221B | 09-043 | 10-001A | 10-034 | 11-006 | 11-026 | 12-021F | 12-054F |  |  |  |  |  |  |  |  |  |  |  |  |
| 195221220 |  | Module #28 Matrix Fabrication | 73d | 2010-10-01 A | 2011-01-24 A | 9-110M | 100% |  |  | PROCUREMENT>$50K 69 NO ESCALATION | 12,842 |  |  | 0 | 12842 | 1284200 | 100 | 0 | 12842 | CHUDAKOV | 1 | 1 | D | APP | P | EUGENE C | 5221B | 09-043 | 10-001A | 10-034 | 11-006 | 11-026 | 12-021F | 12-054F | 09-014 |  |  |  |  |  |  |  |  |  |  |  |
| 195221225 |  | Module #28 Machining and Shipping | 137d | 2010-10-01 A | 2011-04-25 A | 9-110M | 100% |  |  | PROCUREMENT>$50K 69 NO ESCALATION | 4,607 |  |  | 0 | 4607 | 460700 | 100 | 0 | 4607 | CHUDAKOV | 1 | 1 | D | APP | P | EUGENE C | 5221B | 09-043 | 10-001A | 10-034 | 11-006 | 11-026 | 12-021F | 12-054F |  |  |  |  |  |  |  |  |  |  |  |  |
| 195221230 |  | Module #29 Matrix Fabrication | 97d | 2010-10-01 A | 2011-02-28 A | 9-110M | 100% |  |  | PROCUREMENT>$50K 69 NO ESCALATION | 12,842 |  |  | 0 | 12842 | 1284200 | 100 | 0 | 12842 | CHUDAKOV | 1 | 1 | D | APP | P | EUGENE C | 5221B | 09-043 | 10-001A | 10-034 | 11-006 | 11-026 | 12-021F | 12-054F |  |  |  |  |  |  |  |  |  |  |  |  |
| 195221235 |  | Module #29 Machining and Shipping | 147d | 2010-10-01 A | 2011-05-09 A | 9-110M | 100% |  |  | PROCUREMENT>$50K 69 NO ESCALATION | 4,607 |  |  | 0 | 4607 | 460700 | 100 | 0 | 4607 | CHUDAKOV | 1 | 1 | D | APP | P | EUGENE C | 5221B | 09-043 | 10-001A | 10-034 | 11-006 | 11-026 | 12-021F | 12-054F |  |  |  |  |  |  |  |  |  |  |  |  |
| 195221240 |  | Module #30 Matrix Fabrication | 97d | 2010-10-01 A | 2011-02-28 A | 9-110M | 100% |  |  | PROCUREMENT>$50K 69 NO ESCALATION | 12,842 |  |  | 0 | 12842 | 1284200 | 100 | 0 | 12842 | CHUDAKOV | 1 | 1 | D | APP | P | EUGENE C | 5221B | 09-043 | 10-001A | 10-034 | 11-006 | 11-026 | 12-021F | 12-054F |  |  |  |  |  |  |  |  |  |  |  |  |
| 195221245 |  | Module #30 Machining and Shipping | 147d | 2010-10-01 A | 2011-05-09 A | 9-110M | 100% |  |  | PROCUREMENT>$50K 69 NO ESCALATION | 4,607 |  |  | 0 | 4607 | 460700 | 100 | 0 | 4607 | CHUDAKOV | 1 | 1 | D | APP | P | EUGENE C | 5221B | 09-043 | 10-001A | 10-034 | 11-006 | 11-026 | 12-021F | 12-054F |  |  | 1 |  |  |  |  |  |  |  |  |  |
| 195221250 |  | Module #31 Matrix Fabrication | 112d | 2010-10-01 A | 2011-03-21 A | 9-110M | 100% |  |  | PROCUREMENT>$50K 69 NO ESCALATION | 12,842 |  |  | 0 | 12842 | 1284200 | 100 | 0 | 12842 | CHUDAKOV | 1 | 1 | D | APP | P | EUGENE C | 5221B | 09-043 | 10-001A | 10-034 | 11-006 | 11-026 | 12-021F | 12-054F | 09-014 |  |  |  |  |  |  |  |  |  |  |  |
| 195221255 |  | Module #31 Machining and Shipping | 147d | 2010-10-01 A | 2011-05-09 A | 9-110M | 100% |  |  | PROCUREMENT>$50K 69 NO ESCALATION | 4,607 |  |  | 0 | 4607 | 460700 | 100 | 0 | 4607 | CHUDAKOV | 1 | 1 | D | APP | P | EUGENE C | 5221B | 09-043 | 10-001A | 10-034 | 11-006 | 11-026 | 12-021F | 12-054F |  |  | 1 | 09-027 | 09-027 |  |  |  |  |  |  |  |
| 195221260 |  | Module #32 Matrix Fabrication | 112d | 2010-10-01 A | 2011-03-21 A | 9-110M | 100% |  |  | PROCUREMENT>$50K 69 NO ESCALATION | 12,842 |  |  | 0 | 12842 | 1284200 | 100 | 0 | 12842 | CHUDAKOV | 1 | 1 | D | APP | P | EUGENE C | 5221B | 09-043 | 10-001A | 10-034 | 11-006 | 11-026 | 12-021F | 12-054F |  |  | 1 | 09-027 | 09-027 |  |  |  |  |  |  |  |
| 195221265 |  | Module #32 Machining and Shipping | 147d | 2010-10-01 A | 2011-05-09 A | 9-110M | 100% |  |  | PROCUREMENT>$50K 69 NO ESCALATION | 4,607 |  |  | 0 | 4607 | 460700 | 100 | 0 | 4607 | CHUDAKOV | 1 | 1 | D | APP | P | EUGENE C | 5221B | 09-043 | 10-001A | 10-034 | 11-006 | 11-026 | 12-021F | 12-054F |  |  | 1 | 09-027 | 09-027 |  |  |  |  |  |  |  |
| 195221270 |  | Module #33 Matrix Fabrication | 137d | 2010-10-01 A | 2011-04-25 A | 9-110M | 100% |  |  | PROCUREMENT>$50K 69 NO ESCALATION | 12,842 |  |  | 0 | 12842 | 1284200 | 100 | 0 | 12842 | CHUDAKOV | 1 | 1 | D | APP | P | EUGENE C | 5221B | 09-043 | 10-001A | 10-034 | 11-006 | 11-026 | 12-021F | 12-054F |  |  | 1 |  |  |  |  |  |  |  |  |  |
| 195221275 |  | Module #33 Machining and Shipping | 171d | 2010-10-01 A | 2011-06-13 A | 9-110M | 100% |  |  | PROCUREMENT>$50K 69 NO ESCALATION | 4,607 |  |  | 0 | 4607 | 460700 | 100 | 0 | 4607 | CHUDAKOV | 1 | 1 | D | APP | P | EUGENE C | 5221B | 09-043 | 10-001A | 10-034 | 11-006 | 11-026 | 12-021F | 12-054F |  |  | 1 | 09-027 | 09-027 |  |  |  |  |  |  |  |
| 195221285 |  | Module #34 Matrix Fabrication | 137d | 2010-10-01 A | 2011-04-25 A | 9-110M | 100% |  |  | PROCUREMENT>$50K 69 NO ESCALATION | 12,842 |  |  | 0 | 12842 | 1284200 | 100 | 0 | 12842 | CHUDAKOV | 1 | 1 | D | APP | P | EUGENE C | 5221B | 09-043 | 10-001A | 10-034 | 11-006 | 11-026 | 12-021F | 12-054F |  |  | 1 |  |  |  |  |  |  |  |  |  |
| 195221290 |  | Module #34 Machining and Shipping | 171d | 2010-10-01 A | 2011-06-13 A | 9-110M | 100% |  |  | PROCUREMENT>$50K 69 NO ESCALATION | 4,607 |  |  | 0 | 4607 | 460700 | 100 | 0 | 4607 | CHUDAKOV | 1 | 1 | D | APP | P | EUGENE C | 5221B | 09-043 | 10-001A | 10-034 | 11-006 | 11-026 | 12-021F | 12-054F |  |  | 1 | 09-027 | 09-027 |  |  |  |  |  |  |  |
| 195221295 |  | Module #35 Matrix Fabrication | 142d | 2010-10-01 A | 2011-05-02 A | 9-110M | 100% |  |  | PROCUREMENT>$50K 69 NO ESCALATION | 12,842 |  |  | 0 | 12842 | 1284200 | 100 | 0 | 12842 | CHUDAKOV | 1 | 1 | D | APP | P | EUGENE C | 5221B | 09-043 | 10-001A | 10-034 | 11-006 | 11-026 | 12-021F | 12-054F | 09-014 |  |  |  |  |  |  |  |  |  |  |  |
| 195221300 |  | Module #35 Machining and Shipping | 171d | 2010-10-01 A | 2011-06-13 A | 9-110M | 100% |  |  | PROCUREMENT>$50K 69 NO ESCALATION | 4,607 |  |  | 0 | 4607 | 460700 | 100 | 0 | 4607 | CHUDAKOV | 1 | 1 | D | APP | P | EUGENE C | 5221B | 09-043 | 10-001A | 10-034 | 11-006 | 11-026 | 12-021F | 12-054F | 09-014 |  |  |  |  |  |  |  |  |  |  |  |
| 195221305 |  | Module #36 Matrix Fabrication | 145d | 2010-10-01 A | 2011-05-05 A | 9-110M | 100% |  |  | PROCUREMENT>$50K 69 NO ESCALATION | 12,842 |  |  | 0 | 12842 | 1284200 | 100 | 0 | 12842 | CHUDAKOV | 1 | 1 | D | APP | P | EUGENE C | 5221B | 09-043 | 10-001A | 10-034 | 11-006 | 11-026 | 12-021F | 12-054F | 09-014 |  |  |  |  |  |  |  |  |  |  |  |
| 195221310 |  | Module #36 Machining and Shipping | 171d | 2010-10-01 A | 2011-06-13 A | 9-110M | 100% |  |  | PROCUREMENT>$50K 69 NO ESCALATION | 4,607 |  |  | 0 | 4607 | 460700 | 100 | 0 | 4607 | CHUDAKOV | 1 | 1 | D | APP | P | EUGENE C | 5221B | 09-043 | 10-001A | 10-034 | 11-006 | 11-026 | 12-021F | 12-054F | 09-014 |  |  |  |  |  |  |  |  |  |  |  |
| 195221315 |  | Module #37 Matrix Fabrication | 160d | 2010-10-01 A | 2011-05-26 A | 9-110M | 100% |  |  | PROCUREMENT>$50K 69 NO ESCALATION | 12,842 |  |  | 0 | 12842 | 1284200 | 100 | 0 | 12842 | CHUDAKOV | 1 | 1 | D | APP | P | EUGENE C | 5221B | 09-043 | 10-001A | 10-034 | 11-006 | 11-026 | 12-021F | 12-054F | 09-014 |  |  |  |  |  |  |  |  |  |  |  |
| 195221320 |  | Module #37 Machining and Shipping | 221d | 2010-10-01 A | 2011-08-23 A | 9-110M | 100% |  |  | PROCUREMENT>$50K 69 NO ESCALATION | 4,607 |  |  | 0 | 4607 | 460700 | 100 | 0 | 4607 | CHUDAKOV | 1 | 1 | D | APP | P | EUGENE C | 5221B | 09-043 | 10-001A | 10-034 | 11-006 | 11-026 | 12-021F | 12-054F |  |  |  |  |  |  |  |  |  |  |  |  |
| 195221325 |  | Module #38 Matrix Fabrication | 162d | 2010-10-01 A | 2011-05-31 A | 9-110M | 100% |  |  | PROCUREMENT>$50K 69 NO ESCALATION | 12,842 |  |  | 0 | 12842 | 1284200 | 100 | 0 | 12842 | CHUDAKOV | 1 | 1 | D | APP | P | EUGENE C | 5221B | 09-043 | 10-001A | 10-034 | 11-006 | 11-026 | 12-021F | 12-054F | 09-014 |  |  |  |  |  |  |  |  |  |  |  |
| 195221330 |  | Module #38 Machining and Shipping | 221d | 2010-10-01 A | 2011-08-23 A | 9-110M | 100% |  |  | PROCUREMENT>$50K 69 NO ESCALATION | 4,607 |  |  | 0 | 4607 | 460700 | 100 | 0 | 4607 | CHUDAKOV | 1 | 1 | D | APP | P | EUGENE C | 5221B | 09-043 | 10-001A | 10-034 | 11-006 | 11-026 | 12-021F | 12-054F |  |  |  |  |  |  |  |  |  |  |  |  |
| 195221335 |  | Module #39 Matrix Fabrication | 184d | 2010-10-01 A | 2011-06-30 A | 9-110M | 100% |  |  | PROCUREMENT>$50K 69 NO ESCALATION | 12,842 |  |  | 0 | 12842 | 1284200 | 100 | 0 | 12842 | CHUDAKOV | 1 | 1 | D | APP | P | EUGENE C | 5221B | 09-043 | 10-001A | 10-034 | 11-006 | 11-026 | 12-021F | 12-054F |  |  |  |  |  |  |  |  |  |  |  |  |
| 195221340 |  | Module #39 Machining and Shipping | 221d | 2010-10-01 A | 2011-08-23 A | 9-110M | 100% |  |  | PROCUREMENT>$50K 69 NO ESCALATION | 4,607 |  |  | 0 | 4607 | 460700 | 100 | 0 | 4607 | CHUDAKOV | 1 | 1 | D | APP | P | EUGENE C | 5221B | 09-043 | 10-001A | 10-034 | 11-006 | 11-026 | 12-021F | 12-054F |  |  |  |  |  |  |  |  |  |  |  |  |
| 195221345 |  | Module #40 Matrix Fabrication | 184d | 2010-10-01 A | 2011-06-30 A | 9-110M | 100% |  |  | PROCUREMENT>$50K 69 NO ESCALATION | 12,842 |  |  | 0 | 12842 | 1284200 | 100 | 0 | 12842 | CHUDAKOV | 1 | 1 | D | APP | P | EUGENE C | 5221B | 09-043 | 10-001A | 10-034 | 11-006 | 11-026 | 12-021F | 12-054F |  |  |  |  |  |  |  |  |  |  |  |  |

Notes:
- 195221000: Corrective Actions: Deleted FY12 funding predecessor since it is applied to this activities / successor.
- 195221001: Corrective Actions: Deleted FY12 funding predecessor since it is applied to this activities / successor.
- 195221020: Explanation: Start taken for obligation purposes...Progress to be taken as LOE on Baseline / dates
- 195221025: Explanation: Start taken for obligation purposes...Progress to be taken as LOE on Baseline / dates

| ID | Activity | Type | Duration | Start | Finish | Predecessors | Complete | Planned start | Planned finish | Resources | Cost | Remaining Material Cost Based on % Compl | Claimed Material Cost Based on % Complet | Initial Claimed Material Calc | Claimed Material Divider | Calculated Remaining Total Cost | MONTHLY EV COST | RESP - Responsibility | STRT%COMP for CM EVM | FNSH%COMP for CM EVM | 12 GeV 1st level Critical Path | HALL D Related Milestones | Advance Purchase Plan > 500K | EVMS Reporting Codes | CAM RESPONSIBLE | 12 GEV MAJOR PROCUREMENT CATAGORY | CR 09-043 | CR 10-001 | CR 10-034 | CR 11-006 | CR 11-026 | CR 12-021 | CR 12-054 | CR 09-014 | CR 09-027 | CR 09-027 Repair | CR 11-040 | Phil Dev | MARCH!!! | Milestone Level | ReBaseline Actuals Adjustment |
| --- | --- | --- | --- | --- | --- | --- | --- | --- | --- | --- | --- | --- | --- | --- | --- | --- | --- | --- | --- | --- | --- | --- | --- | --- | --- | --- | --- | --- | --- | --- | --- | --- | --- | --- | --- | --- | --- | --- | --- | --- | --- |
| 195221350 | Module #40 Machining and Shipping |  | 221d | 2010-10-01 A | 2011-08-23 A | 9-110M | 100% |  |  | PROCUREMENT>$50K 69 NO ESCALATION | 4,607 | 0 | 4607 | 460700 | 100 | 0 | 4607 | CHUDAKOV | 1 | 1 | 1 | D | APP | P | EUGENE C | 5221B | 09-043 | 10-001A | 10-034 | 11-006 | 11-026 | 12-021F | 12-054F |  |  |  |  |  |  |  |  |
| 195221355 | Module #41 Matrix Fabrication |  | 190d | 2010-10-01 A | 2011-07-11 A | 9-110M | 100% |  |  | PROCUREMENT>$50K 69 NO ESCALATION | 12,842 | 0 | 12842 | 1284200 | 100 | 0 | 12842 | CHUDAKOV | 1 | 1 |  | D | APP | P | EUGENE C | 5221B | 09-043 | 10-001A | 10-034 | 11-006 | 11-026 | 12-021F | 12-054F | 09-014 |  |  |  |  |  |  |  |
| 195221360 | Module #41 Machining and Shipping |  | 259d | 2010-10-01 A | 2011-10-17 A | 9-110M | 100% |  |  | PROCUREMENT>$50K 69 NO ESCALATION | 4,607 | 0 | 4607 | 460700 | 100 | 0 | 4607 | CHUDAKOV | 1 | 1 | 1 | D | APP | P | EUGENE C | 5221B | 09-043 | 10-001A | 10-034 | 11-006 | 11-026 | 12-021F | 12-054F |  | 09-027 | 09-027 |  |  |  |  |  |
| 195221365 | Module #42 Matrix Fabrication |  | 190d | 2010-10-01 A | 2011-07-11 A | 9-110M | 100% |  |  | PROCUREMENT>$50K 69 NO ESCALATION | 12,842 | 0 | 12842 | 1284200 | 100 | 0 | 12842 | CHUDAKOV | 1 | 1 | 1 | D | APP | P | EUGENE C | 5221B | 09-043 | 10-001A | 10-034 | 11-006 | 11-026 | 12-021F | 12-054F |  | 09-027 | 09-027 |  |  |  |  |  |
| 195221370 | Module #42 Machining and Shipping |  | 258d | 2010-10-01 A | 2011-10-15 A | 9-110M | 100% | 2010-10-01 | 2011-10-14 | PROCUREMENT>$50K 69 NO ESCALATION | 4,607 | 0 | 4607 | 460700 | 100 | 0 | 4607 | CHUDAKOV | 1 | 1 | 1 | D | APP | P | EUGENE C | 5221B | 09-043 | 10-001A | 10-034 | 11-006 | 11-026 | 12-021F | 12-054F |  | 09-027 | 09-027 |  |  |  |  |  |
| 195221375 | Module #43 Matrix Fabrication |  | 220d | 2010-10-01 A | 2011-08-22 A | 15221018X FS-200d, 15221145 | 100% |  |  | PROCUREMENT<$50K 60 NO ESCALATION | 12,842 | 0 | 12842 | 1284200 | 100 | 0 | 12842 | CHUDAKOV | 1 | 1 | 1 | D | APP | P | EUGENE C | 5221B | 09-043 | 10-001A | 10-034 | 11-006 | 11-026 | 12-021F | 12-054F |  |  |  |  |  |  |  |  |
| 195221380 | Module #43 Machining and Shipping |  | 258d | 2010-10-01 A | 2011-10-17 A | 9-110M | 100% | 2010-10-01 | 2011-10-14 | PROCUREMENT<$50K 60 NO ESCALATION | 4,607 | 0 | 4607 | 460700 | 100 | 0 | 4607 | CHUDAKOV | 1 | 1 | 1 | D | APP | P | EUGENE C | 5221B | 09-043 | 10-001A | 10-034 | 11-006 | 11-026 | 12-021F | 12-054F |  | 09-027 | 09-027 |  |  |  |  |  |
| 195221385 | Module #44 Matrix Fabrication |  | 220d | 2010-10-01 A | 2011-08-22 A | 9-110M | 100% |  |  | PROCUREMENT<$50K 60 NO ESCALATION; PROCUREMENT>$50K 69 NO ESCALATION | 12,842 | 0 | 12842 | 1284200 | 100 | 0 | 12842 | CHUDAKOV | 1 | 1 | 1 | D | APP | P | EUGENE C | 5221B | 09-043 | 10-001A | 10-034 | 11-006 | 11-026 | 12-021F | 12-054F |  |  |  |  |  |  |  |  |
| 195221390 | Module #44 Machining and Shipping |  | 259d | 2010-10-01 A | 2011-10-17 A | 9-110M | 100% |  |  | PROCUREMENT>$50K 69 NO ESCALATION | 4,607 | 0 | 4607 | 460700 | 100 | 0 | 4607 | CHUDAKOV | 1 | 1 | 1 | D | APP | P | EUGENE C | 5221B | 09-043 | 10-001A | 10-034 | 11-006 | 11-026 | 12-021F | 12-054F |  | 09-027 | 09-027 |  |  |  |  |  |
| 195221395 | Module #45 Matrix Fabrication |  | 221d | 2010-10-01 A | 2011-08-23 A | 9-110M | 100% |  |  | PROCUREMENT>$50K 69 NO ESCALATION | 12,842 | 0 | 12842 | 1284200 | 100 | 0 | 12842 | CHUDAKOV | 1 | 1 | 1 | D | APP | P | EUGENE C | 5221B | 09-043 | 10-001A | 10-034 | 11-006 | 11-026 | 12-021F | 12-054F |  |  |  |  |  |  |  |  |
| 195221400 | Module #45 Machining and Shipping |  | 302d | 2010-10-01 A | 2011-12-19 A | 9-110M | 100% |  |  | PROCUREMENT>$50K 69 NO ESCALATION | 4,607 | 0 | 4607 | 460700 | 100 | 0 | 4607 | CHUDAKOV | 1 | 1 | 1 | D | APP | P | EUGENE C | 5221B | 09-043 | 10-001A | 10-034 | 11-006 | 11-026 | 12-021F | 12-054F |  | 09-027 | 09-027 |  |  |  |  |  |
| 195221405 | Module #46 Matrix Fabrication |  | 221d | 2010-10-01 A | 2011-08-23 A | 9-110M | 100% |  |  | PROCUREMENT>$50K 69 NO ESCALATION | 12,842 | 0 | 12842 | 1284200 | 100 | 0 | 12842 | CHUDAKOV | 1 | 1 | 1 | D | APP | P | EUGENE C | 5221B | 09-043 | 10-001A | 10-034 | 11-006 | 11-026 | 12-021F | 12-054F |  |  |  |  |  |  |  |  |
| 195221410 | Module #46 Machining and Shipping |  | 302d | 2010-10-01 A | 2011-12-19 A | 9-110M | 100% |  |  | PROCUREMENT>$50K 69 NO ESCALATION | 4,607 | 0 | 4607 | 460700 | 100 | 0 | 4607 | CHUDAKOV | 1 | 1 | 1 | D | APP | P | EUGENE C | 5221B | 09-043 | 10-001A | 10-034 | 11-006 | 11-026 | 12-021F | 12-054F |  | 09-027 | 09-027 |  |  |  |  |  |
| 195221415 | Module #47 Matrix Fabrication |  | 259d | 2010-10-01 A | 2011-10-17 A | 9-110M | 100% |  |  | PROCUREMENT>$50K 69 NO ESCALATION | 12,842 | 0 | 12842 | 1284200 | 100 | 0 | 12842 | CHUDAKOV | 1 | 1 | 1 | D | APP | P | EUGENE C | 5221B | 09-043 | 10-001A | 10-034 | 11-006 | 11-026 | 12-021F | 12-054F |  |  |  |  |  |  |  |  |
| 195221420 | Module #47 Machining and Shipping |  | 302d | 2010-10-01 A | 2011-12-19 A | 9-110M | 100% |  |  | PROCUREMENT>$50K 69 NO ESCALATION | 4,607 | 0 | 4607 | 460700 | 100 | 0 | 4607 | CHUDAKOV | 1 | 1 | 1 | D | APP | P | EUGENE C | 5221B | 09-043 | 10-001A | 10-034 | 11-006 | 11-026 | 12-021F | 12-054F |  | 09-027 | 09-027 |  |  |  |  |  |
| 195221425 | Module #48 Matrix Fabrication |  | 264d | 2010-10-01 A | 2011-10-24 A | 9-110M | 100% |  |  | PROCUREMENT>$50K 69 NO ESCALATION | 12,842 | 0 | 12842 | 1284200 | 100 | 0 | 12842 | CHUDAKOV | 1 | 1 | 1 | D | APP | P | EUGENE C | 5221B | 09-043 | 10-001A | 10-034 | 11-006 | 11-026 | 12-021F | 12-054F |  |  |  |  |  |  |  |  |
| 195221430 | Module #48 Machining and Shipping |  | 302d | 2010-10-01 A | 2011-12-19 A | 9-110M | 100% |  |  | PROCUREMENT>$50K 69 NO ESCALATION | 4,607 | 0 | 4607 | 460700 | 100 | 0 | 4607 | CHUDAKOV | 1 | 1 | 1 | D | APP | P | EUGENE C | 5221B | 09-043 | 10-001A | 10-034 | 11-006 | 11-026 | 12-021F | 12-054F |  | 09-027 | 09-027 |  |  |  |  |  |
| 195221450 | USM Peg Point # 1 Initial Order Placed |  | 36d | 2011-06-09 A | 2011-07-29 A | 9-110M FS+168d | 100% |  |  | PROCUREMENT<$50K 60 NO ESCALATION; PROCUREMENT>$50K 69 NO ESCALATION | 282,500 | 0 | 282500 | 28250000 | 100 | 0 | 282500 | CHUDAKOV | 1 | 1 | 1 | D | APP | D | EUGENE C | 5221B | 09-043 | 10-001A | 10-034 | 11-006 | 11-026 |  |  |  | 09-027 | 09-027 | 11-040 |  |  |  |  |
| 195221455 | USM Peg Point # 2 On-site Review passed |  | 134d | 2011-06-09 A | 2011-12-19 A | 195221450 FS-36d | 100% |  |  | PROCUREMENT>$50K 69 NO ESCALATION | 282,500 | 0 | 282500 | 28250000 | 100 | 0 | 282500 | CHUDAKOV | 1 | 1 | 1 | D | APP | D | EUGENE C | 5221B | 09-043 | 10-001A | 10-034 | 11-006 | 11-026 |  |  |  | 09-027 | 09-027 | 11-040 |  |  |  |  |
| 195221460 | USM Peg Point # 3 Batch #1 Arrival at USM |  | 134d | 2011-06-09 A | 2011-12-19 A | 195221455 FS-121d | 100% |  |  | PROCUREMENT>$50K 69 NO ESCALATION | 282,500 | 0 | 282500 | 28250000 | 100 | 0 | 282500 | CHUDAKOV | 1 | 1 | 1 | D | APP | D | EUGENE C | 5221B | 09-043 | 10-001A | 10-034 | 11-006 | 11-026 |  |  |  | 09-027 | 09-027 | 11-040 |  |  |  |  |
| 195221465 | USM Peg Point # 4 Batch #2 Arrival at USM |  | 147d | 2011-06-09 A | 2012-01-16 A | 195221460 FS-138d | 100% | 2011-06-09 | 2012-01-13 | PROCUREMENT>$50K 69 NO ESCALATION | 282,500 | 0 | 282500 | 28250000 | 100 | 0 | 282500 | CHUDAKOV | 1 | 1 | 1 | D | APP | D | EUGENE C | 5221B | 09-043 | 10-001A | 10-034 | 11-006 | 11-026 |  |  |  | 09-027 | 09-027 | 11-040 |  |  |  |  |
| 195221470 | USM Peg Point # 5 Qty. 500 MPPCs tested and shipped to JLab |  | 231d | 2011-06-09 A | 2012-05-14 A | 195221465 FS-158d | 100% |  |  | PROCUREMENT>$50K 69 NO ESCALATION | 18,928 | 0 | 18928 | 1892800 | 100 | 0 | 18928 | CHUDAKOV | 1 | 1 | 1 | D | APP | D | EUGENE C | 5221B | 09-043 | 10-001A | 10-034 | 11-006 | 11-026 |  |  |  | 09-027 | 09-027 | 11-040 |  |  |  |  |
| 195221475 | USM Peg Point # 6 Batch #3 Arrival at USM |  | 231d | 2011-06-09 A | 2012-05-14 A | 195221470 FS-158d | 100% |  |  | PROCUREMENT>$50K 69 NO ESCALATION | 282,500 | 0 | 282500 | 28250000 | 100 | 0 | 282500 | CHUDAKOV | 1 | 1 | 1 | D | APP | D | EUGENE C | 5221B | 09-043 | 10-001A | 10-034 | 11-006 | 11-026 |  |  |  | 09-027 | 09-027 | 11-040 |  |  |  |  |
| 195221480 | USM Peg Point # 7 Qty. 500 MPPCs tested and shipped to JLab |  | 294d | 2011-06-09 A | 2012-08-13 A | 195221475 FS-178d | 100% |  |  | PROCUREMENT>$50K 69 NO ESCALATION | 18,928 | 0 | 18928 | 1892800 | 100 | 0 | 18928 | CHUDAKOV | 1 | 1 | 1 | D | APP | D | EUGENE C | 5221B | 09-043 | 10-001A | 10-034 | 11-006 | 11-026 |  |  |  | 09-027 | 09-027 | 11-040 |  |  |  |  |
| 195221485 | USM Peg Point # 8 Batch #4 Arrival at USM |  | 388d | 2011-06-09 A | 2013-03-11 A | 195221480 FS-178d | 100% | 2011-06-09 | 2013-01-03 | PROCUREMENT>$50K 69 NO ESCALATION | 169,500 | 0 | 169500 | 16950000 | 100 | 0 | 169500 | CHUDAKOV | 1 | 1 | 1 | D | APP | D | EUGENE C | 5221B | 09-043 | 10-001A | 10-034 | 11-006 | 11-026 |  |  |  | 09-027 | 09-027 | 11-040 | MP | XX |  |  |
| 195221490 | USM Peg Point # 9 Qty. 500 MPPCs tested and shipped to JLab |  | 318d | 2011-06-09 A | 2012-09-17 A | 195221485 FS-200d | 100% |  |  | PROCUREMENT>$50K 69 NO ESCALATION | 18,928 | 0 | 18928 | 1892800 | 100 | 0 | 18928 | CHUDAKOV | 1 | 1 | 1 | D | APP | D | EUGENE C | 5221B | 09-043 | 10-001A | 10-034 | 11-006 | 11-026 |  |  |  | 09-027 | 09-027 | 11-040 |  |  |  |  |
| 195221495 | USM Peg Point # 10 Qty. 500 MPPCs tested and shipped to JLab |  | 392d | 2011-06-09 A | 2013-03-11 A | 195221490 FS-200d | 100% | 2011-06-09 | 2013-01-09 | PROCUREMENT>$50K 69 NO ESCALATION | 18,928 | 0 | 18928 | 1892800 | 100 | 0 | 18928 | CHUDAKOV | 1 | 1 | 1 | D | APP | D | EUGENE C | 5221B | 09-043 | 10-001A | 10-034 | 11-006 | 11-026 |  |  |  | 09-027 | 09-027 | 11-040 |  | XX |  |  |
| 195221500 | USM Peg Point # 11 Qty. 500 MPPCs tested and shipped to JLab |  | 388d | 2011-06-09 A | 2013-04-15 A | 195221495 FS-221d | 100% | 2011-06-09 | 2013-01-03 | PROCUREMENT>$50K 69 NO ESCALATION | 18,928 | 0 | 18928 | 1892800 | 100 | 0 | 18928 | CHUDAKOV | 1 | 1 | 1 | D | APP | D | EUGENE C | 5221B | 09-043 | 10-001A | 10-034 | 11-006 | 11-026 |  |  |  | 09-027 | 09-027 | 11-040 |  | XX |  |  |
| 195221505 | USM Peg Point # 12 Qty. 300 MPPCs tested and shipped to JLab |  | 411d | 2011-06-09 A | 2013-04-15 A | 195221500 FS-243d | 100% | 2011-06-09 | 2013-02-06 | PROCUREMENT>$50K 69 NO ESCALATION | 11,760 | 0 | 11760 | 1176000 | 100 | 0 | 11760 | CHUDAKOV | 1 | 1 | 1 | D | APP | D | EUGENE C | 5221B | 09-043 | 10-001A | 10-034 | 11-006 | 11-026 |  |  |  | 09-027 | 09-027 | 11-040 |  | XX |  |  |
| 195221435M | All Barrel Cal Mods Comptd & Shipped | milestone | 0d | 2011-12-19 A | 2011-12-19 A | 195221245, 195221250, 195221100, 195221165, 195221140, 195221170, 195221095, 195221045, 195221210, 195221285, 195221375, 195221310, 195221315, 195221220, 195221110, 195221345, 15221173, 15221265, 195221360, 195221370, 195221030, 195221320, 195221135, 195221300, 195221150, 195221425, 195221410, 195221200, 195221085, 195221125, 195221160, 195221155, 195221040, 195221365, 195221215, 195221120, 195221115, 195221415, 195221350, 15221215, 15221235, 15221200, 195221075, 195221145, 195221290, 195221025, 195221225, 195221195, 195221235, 195221385, 195221180, 195221355, 15221250, 15221210, 15221240, 15221270, 15221255, 195221270, 195221105, 195221070, 195221230, 195221255, 195221295, 15221230, 15221225, 195221330, 195221400, 195221055, 195221060, 195221090, 195221275, 195221405, 195221065, 195221380, 195221175, 195221340, 15221220, 195221335, 195221240, 195221420, 195221205, 195221265, 195221035, 195221050, 195221395, 195221305, 15221260, 15221275, 15221205, 15221245, 195221080, 195221325, 195221260, 195221430, 195221390, 195221130, 195221185, 195221190 | 100% | 2012-12-31 | 2012-12-31 |  |  |  |  |  |  |  | 0 | CHUDAKOV | 1 | 1 | 1 | D | APP | M | EUGENE C | 5221B | 09-043 |  | 10-034 | 11-006 | 11-026 | 12-021F | 12-054F |  |  |  |  |  |  | 6 |  |
| 195221510 | Re-Baseline Actuals Adjustment |  | 1d | 2013-08-30 A | 2013-08-30 A |  | 100% | 2013-09-03 | 2013-09-03 | PROCUREMENT>$50K 69 NO ESCALATION | -1,032.62 |  |  |  | 100 |  |  |  |  |  |  |  |  |  |  |  |  |  |  |  |  |  |  |  |  |  |  |  |  |  | ADJ |

| ID | WBS | Activity | Type | Duration | Start | Finish | Predecessors | Complete | Planned start | Planned finish | Calendar | Resources | Cost | MONTHLY EV COST | RESP - Responsibility | STRT%COMP for CM EVM | FNSH%COMP for CM EVM | Advance Purchase Plan > 500K | EVMS Reporting Codes | CAM RESPONSIBLE | CR 10-009 | CR 11-026 | CR 12-054 | Remaining Material Cost Based on % Compl | Claimed Material Cost Based on % Complet | Initial Claimed Material Calc | Claimed Material Divider | Calculated Remaining Total Cost | CR 11-VA2 | MARCH!!! | ReBaseline Actuals Adjustment | Original Activity ID Rebaseline | PRIOR MONTH EV COST | HALL D Related Milestones | CR 10-046 | CR 11-006 | CR 13-007 | BOE Procurement | CR 13-015 | Post Rebaseline | Obligated Prior to Rebaseline |
| --- | --- | --- | --- | --- | --- | --- | --- | --- | --- | --- | --- | --- | --- | --- | --- | --- | --- | --- | --- | --- | --- | --- | --- | --- | --- | --- | --- | --- | --- | --- | --- | --- | --- | --- | --- | --- | --- | --- | --- | --- | --- |
|  | 2 | **1.9.5.2.2.2 HALL D FORWARD CALORIMETER** |  |  | 2010-03-01 | 2013-09-23 |  |  |  |  |  |  |  |  |  |  |  |  |  |  |  |  |  |  |  |  |  |  |  |  |  |  |  |  |  |  |  |  |  |  |  |
| 195222010 |  | Prepare top level drawing documentation |  | 66d | 2010-03-01 A | 2010-06-01 A | 9-100M FS+97d | 100% |  |  |  |  |  | 0 | CHUDAKOV | 1 | 1 | APP | P | EUGENE C | 10-009 | 11-026 | 12-054F |  |  |  |  |  |  |  |  |  |  |  |  |  |  |  |  |  |  |
| 195222020 |  | Build Steel Tubes (fab) |  | 168d | 2010-03-01 A | 2010-10-25 A | 195222010 FS-43d, 195222015M FS-43d | 100% |  |  |  | PROCUREMENT<$50K 60 NO ESCALATION; PROCUREMENT>$50K 69 NO ESCALATION | 52,686 | 52686 | CHUDAKOV | 1 | 1 | APP | D | EUGENE C | 10-009 | 11-026 | 12-054F | 0 | 52686 | 5268600 | 100 | 0 |  |  |  |  |  |  |  |  |  |  |  |  |  |
| 195222025 |  | Build Steel Tubes (coat) |  | 193d | 2010-03-01 A | 2010-12-01 A | 195222020 FS-87d | 100% |  |  |  | PROCUREMENT>$50K 69 NO ESCALATION | 1,409 | 1409 | CHUDAKOV | 1 | 1 | APP | D | EUGENE C | 10-009 | 11-026 | 12-054F | 0 | 1409 | 140900 | 100 | 0 |  |  |  |  |  |  |  |  |  |  |  |  |  |
| 195222030 |  | Build Tube Straps (procure material) |  | 109d | 2010-03-01 A | 2010-08-02 A | 195222025 FS-108d | 100% |  |  |  | PROCUREMENT>$50K 69 NO ESCALATION | 1,932 | 1932 | CHUDAKOV | 1 | 1 | APP | D | EUGENE C | 10-009 | 11-026 | 12-054F | 0 | 1932 | 193200 | 100 | 0 |  |  |  |  |  |  |  |  |  |  |  |  |  |
| 195222035 |  | Build Tube Straps (shear) |  | 94d | 2010-03-01 A | 2010-07-12 A | 195222030 FS-87d | 100% |  |  |  | PROCUREMENT>$50K 69 NO ESCALATION | 2,239 | 2239 | CHUDAKOV | 1 | 1 | APP | D | EUGENE C | 10-009 | 11-026 | 12-054F | 0 | 2239 | 223900 | 100 | 0 |  |  |  |  |  |  |  |  |  |  |  |  |  |
| 195222040 |  | Build Jack Plates |  | 119d | 2010-03-01 A | 2010-08-16 A | 195222035 FS-108d | 100% |  |  |  | PROCUREMENT>$50K 69 NO ESCALATION | 21,017 | 21017 | CHUDAKOV | 1 | 1 | APP | D | EUGENE C | 10-009 | 11-026 | 12-054F | 0 | 21017 | 2101700 | 100 | 0 |  |  |  |  |  |  |  |  |  |  |  |  |  |
| 195222045 |  | Build Face Plates |  | 93d | 2010-03-01 A | 2010-07-09 A | 195222040 FS-108d | 100% |  |  |  | PROCUREMENT>$50K 69 NO ESCALATION | 6,862 | 6862 | CHUDAKOV | 1 | 1 | APP | D | EUGENE C | 10-009 | 11-026 | 12-054F | 0 | 6862 | 686200 | 100 | 0 |  |  |  |  |  |  |  |  |  |  |  |  |  |
| 195222050 |  | Pb Glass Preparation (weld straps) |  | 140d | 2010-03-01 A | 2010-09-15 A | 195222045 FS-65d | 100% |  |  |  | PROCUREMENT>$50K 69 NO ESCALATION | 13,830 | 13830 | CHUDAKOV | 1 | 1 | APP | D | EUGENE C | 10-009 | 11-026 | 12-054F | 0 | 13830 | 1383000 | 100 | 0 |  |  |  |  |  |  |  |  |  |  |  |  |  |
| 195222055 |  | Pb Glass Preparation (clean and wrap glass) |  | 263d | 2010-03-01 A | 2011-03-21 A | 195222050 FS-172d | 100% |  |  |  | PROCUREMENT>$50K 69 NO ESCALATION | 9,267 | 9267 | CHUDAKOV | 1 | 1 | APP | D | EUGENE C | 10-009 | 11-026 | 12-054F | 0 | 9267 | 926700 | 100 | 0 |  |  |  |  |  |  |  |  |  |  |  |  |  |
| 195222060 |  | Pb Glass Preparation (attach sheild) |  | 263d | 2010-03-01 A | 2011-03-21 A | 195222055 FS-209d | 100% |  |  |  | PROCUREMENT>$50K 69 NO ESCALATION | 10,229 | 10229 | CHUDAKOV | 1 | 1 | APP | D | EUGENE C | 10-009 | 11-026 | 12-054F | 0 | 10229 | 1022900 | 100 | 0 |  |  |  |  |  |  |  |  |  |  |  |  |  |
| 195222065 |  | Pb Glass Preparation (prepare shippment) |  | 263d | 2010-03-01 A | 2011-03-21 A | 195222060 FS-248d | 100% |  |  |  | PROCUREMENT>$50K 69 NO ESCALATION | 3,120 | 3120 | CHUDAKOV | 1 | 1 | APP | D | EUGENE C | 10-009 | 11-026 | 12-054F | 0 | 3120 | 312000 | 100 | 0 |  |  |  |  |  |  |  |  |  |  |  |  |  |
| 195222070 |  | Replacement pmts Testing |  | 188d | 2010-03-01 A | 2010-11-22 A | 195222065 FS-271d | 100% |  |  |  | PROCUREMENT>$50K 69 NO ESCALATION | 1,040 | 1040 | CHUDAKOV | 1 | 1 | APP | D | EUGENE C | 10-009 | 11-026 | 12-054F | 0 | 1040 | 104000 | 100 | 0 |  |  |  |  |  |  |  |  |  |  |  |  |  |
| 195222075 |  | PMT Base Rods (procure) |  | 308d | 2010-03-01 A | 2011-05-23 A | 195222070 FS-130d | 100% |  |  |  | PROCUREMENT>$50K 69 NO ESCALATION | 22,847 | 22847 | CHUDAKOV | 1 | 1 | APP | D | EUGENE C | 10-009 | 11-026 | 12-054F | 0 | 22847 | 2284700 | 100 | 0 |  |  |  |  |  |  |  |  |  |  |  |  |  |
| 195222080 |  | PMT Base Housing (procure tubes) |  | 248d | 2010-03-01 A | 2011-02-28 A | 195222075 FS-108d | 100% |  |  |  | PROCUREMENT>$50K 69 NO ESCALATION | 9,581 | 9581 | CHUDAKOV | 1 | 1 | APP | D | EUGENE C | 10-009 | 11-026 | 12-054F | 0 | 9581 | 958100 | 100 | 0 |  |  |  |  |  |  |  |  |  |  |  |  |  |
| 195222085 |  | PMT Base Housing (machine tubes) |  | 378d | 2010-03-01 A | 2011-08-31 A | 195222080 FS-87d | 100% |  |  |  | PROCUREMENT>$50K 69 NO ESCALATION | 3,864 | 3864 | CHUDAKOV | 1 | 1 | APP | D | EUGENE C | 10-009 | 11-026 | 12-054F | 0 | 3864 | 386400 | 100 | 0 |  |  |  |  |  |  |  |  |  |  |  |  |  |
| 195222090 |  | PMT Base Housing (fabricate sockets) |  | 168d | 2010-03-01 A | 2010-10-25 A | 195222085 FS-130d | 100% |  |  |  | PROCUREMENT>$50K 69 NO ESCALATION | 16,240 | 16240 | CHUDAKOV | 1 | 1 | APP | D | EUGENE C | 10-009 | 11-026 | 12-054F | 0 | 16240 | 1624000 | 100 | 0 |  |  |  |  |  |  |  |  |  |  |  |  |  |
| 195222095 |  | PMT Base Housing (insert pins) |  | 263d | 2010-03-01 A | 2011-03-21 A | 195222090 FS-108d | 100% |  |  |  | PROCUREMENT>$50K 69 NO ESCALATION | 4,159 | 4159 | CHUDAKOV | 1 | 1 | APP | D | EUGENE C | 10-009 | 11-026 | 12-054F | 0 | 4159 | 415900 | 100 | 0 |  |  |  |  |  |  |  |  |  |  |  |  |  |
| 195222100 |  | PMT Base Housing (package for assembly) |  | 263d | 2010-03-01 A | 2011-03-21 A | 195222095 FS-130d | 100% |  |  |  | PROCUREMENT>$50K 69 NO ESCALATION | 208 | 208 | CHUDAKOV | 1 | 1 | APP | D | EUGENE C | 10-009 | 11-026 | 12-054F | 0 | 208 | 20800 | 100 | 0 |  |  |  |  |  |  |  |  |  |  |  |  |  |
| 195222105 |  | PMT Base Housing (back plate) |  | 263d | 2010-03-01 A | 2011-03-21 A | 195222100 FS-130d | 100% |  |  |  | PROCUREMENT>$50K 69 NO ESCALATION | 12,628 | 12628 | CHUDAKOV | 1 | 1 | APP | D | EUGENE C | 10-009 | 11-026 | 12-054F | 0 | 12628 | 1262800 | 100 | 0 |  |  |  |  |  |  |  |  |  |  |  |  |  |
| 195222110 |  | PMT Base Housing assembly |  | 188d | 2010-03-01 A | 2010-11-22 A | 195222105 FS-108d | 100% |  |  |  | PROCUREMENT>$50K 69 NO ESCALATION | 1,040 | 1040 | CHUDAKOV | 1 | 1 | APP | D | EUGENE C | 10-009 | 11-026 | 12-054F | 0 | 1040 | 104000 | 100 | 0 |  |  |  |  |  |  |  |  |  |  |  |  |  |
| 195222115 |  | Prepare Base Circuit Fabrication Drawings |  | 168d | 2010-03-01 A | 2010-10-25 A | 195222110 FS-40d | 100% |  |  |  | PROCUREMENT>$50K 69 NO ESCALATION | 11,079 | 11079 | CHUDAKOV | 1 | 1 | APP | D | EUGENE C | 10-009 | 11-026 | 12-054F | 0 | 11079 | 1107900 | 100 | 0 |  |  |  |  |  |  |  |  |  |  |  |  |  |
| 195222125 |  | First Circuit Board Run PCB's (1/6 total) |  | 206d | 2010-03-01 A | 2010-12-20 A | 195222120M FS-108d, 195222115 FS-108d | 100% |  |  |  | PROCUREMENT>$50K 69 NO ESCALATION | 12,718 | 12718 | CHUDAKOV | 1 | 1 | APP | D | EUGENE C | 10-009 | 11-026 | 12-054F | 0 | 12718 | 1271800 | 100 | 0 |  |  |  |  |  |  |  |  |  |  |  |  |  |
| 195222130 |  | First Circuit Board Run Parts (1/6 total) |  | 162d | 2010-03-01 A | 2010-10-15 A | 195222125 FS-151d | 100% |  |  |  | PROCUREMENT>$50K 69 NO ESCALATION | 84,170 | 84170 | CHUDAKOV | 1 | 1 | APP | D | EUGENE C | 10-009 | 11-026 | 12-054F | 0 | 84170 | 8417000 | 100 | 0 |  |  |  |  |  |  |  |  |  |  |  |  |  |
| 195222135 |  | First Circuit Board Run Populate (1/6 total) |  | 215d | 2010-03-01 A | 2011-01-10 A | 195222130 FS-130d | 100% |  |  |  | PROCUREMENT>$50K 69 NO ESCALATION | 35,709 | 35709 | CHUDAKOV | 1 | 1 | APP | D | EUGENE C | 10-009 | 11-026 | 12-054F | 0 | 35709 | 3570900 | 100 | 0 |  |  |  |  |  |  |  |  |  |  |  |  |  |
| 195222140 |  | First Circuit Board Tester (1/6 total) |  | 206d | 2010-03-01 A | 2010-12-20 A | 195222135 FS-151d | 100% |  |  |  | PROCUREMENT>$50K 69 NO ESCALATION | 4,088 | 4088 | CHUDAKOV | 1 | 1 | APP | D | EUGENE C | 10-009 | 11-026 | 12-054F | 0 | 4088 | 408800 | 100 | 0 |  |  |  |  |  |  |  |  |  |  |  |  |  |
| 195222145 |  | First Circuit Board Run Assembly (1/6 total) |  | 263d | 2010-03-01 A | 2011-03-21 A | 195222140 FS-130d | 100% |  |  |  | PROCUREMENT>$50K 69 NO ESCALATION | 13,226 | 13226 | CHUDAKOV | 1 | 1 | APP | D | EUGENE C | 10-009 | 11-026 | 12-054F | 0 | 13226 | 1322600 | 100 | 0 |  |  |  |  |  |  |  |  |  |  |  |  |  |
| 195222150 |  | First Circuit Board Run Testing (1/6 total) |  | 342d | 2010-03-01 A | 2011-07-12 A | 195222145 FS-209d | 100% |  |  |  | PROCUREMENT>$50K 69 NO ESCALATION | 44,316 | 44316 | CHUDAKOV | 1 | 1 | APP | D | EUGENE C | 10-009 | 11-026 | 12-054F | 0 | 44316 | 4431600 | 100 | 0 |  |  |  |  |  |  |  |  |  |  |  |  |  |
| 195222155 |  | Second Circuit Board Run PCBs (5/6 total) |  | 430d | 2010-03-01 A | 2011-11-14 A | 195222150 FS-271d | 100% |  |  |  | PROCUREMENT>$50K 69 NO ESCALATION | 33,283 | 33283 | CHUDAKOV | 1 | 1 | APP | D | EUGENE C | 10-009 | 11-026 | 12-054F | 0 | 33283 | 3328300 | 100 | 0 | 11-VA2 |  |  |  |  |  |  |  |  |  |  |  |  |
| 195222160 |  | Second Circuit Board Run Parts (5/6 total) |  | 395d | 2010-03-01 A | 2011-09-26 A | 195222155 FS-292d | 100% |  |  |  | PROCUREMENT>$50K 69 NO ESCALATION | 186,396 | 186396 | CHUDAKOV | 1 | 1 | APP | D | EUGENE C | 10-009 | 11-026 | 12-054F | 0 | 186396 | 18639600 | 100 | 0 | 11-VA2 |  |  |  |  |  |  |  |  |  |  |  |  |
| 195222165 |  | Second Circuit Board Run Populate (5/6 total) |  | 637d | 2010-03-01 A | 2012-09-17 A | 195222160 FS-292d | 100% |  |  |  | PROCUREMENT>$50K 69 NO ESCALATION | 156,132 | 156132 | CHUDAKOV | 1 | 1 | APP | D | EUGENE C | 10-009 | 11-026 | 12-054F | 0 | 156132 | 15613200 | 100 | 0 | 11-VA2 |  |  |  |  |  |  |  |  |  |  |  |  |
| 195222170 |  | Second Circuit Board Run Assemble and Test (5/6 total) |  | 700d | 2010-03-01 A | 2013-02-11 A | 195222165 FS-313d | 100% | 2010-03-01 | 2012-12-17 |  | PROCUREMENT>$50K 69 NO ESCALATION | 64,990 | 64990 | CHUDAKOV | 1 | 1 | APP | D | EUGENE C | 10-009 | 11-026 | 12-054F | 0 | 64990 | 6499000 | 100 | 0 | 11-VA2 | XX |  |  |  |  |  |  |  |  |  |  |  |
| 195222175 |  | Prepare Pb Glass Drawings |  | 259d | 2010-03-01 A | 2011-03-15 A | 195222170 FS-457d | 100% |  |  |  |  |  | 0 | CHUDAKOV | 1 | 1 | APP | D | EUGENE C | 10-009 | 11-026 | 12-054F |  |  |  |  |  |  |  |  |  |  |  |  |  |  |  |  |  |  |
| 195222185 |  | Procure Materials for PB Glass Support |  | 510d | 2010-03-01 A | 2012-03-19 A | 195222175 FS-65d, 195222180M FS-65d | 100% |  |  |  | PROCUREMENT>$50K 69 NO ESCALATION | 11,882 | 11882 | CHUDAKOV | 1 | 1 | APP | D | EUGENE C | 10-009 | 11-026 | 12-054F | 0 | 11882 | 1188200 | 100 | 0 |  |  |  |  |  |  |  |  |  |  |  |  |  |
| 195222190 |  | Machine Componets for PB Glass Support |  | 570d | 2010-03-01 A | 2012-06-13 A | 195222185 FS-151d | 100% |  |  |  | PROCUREMENT>$50K 69 NO ESCALATION | 2,778 | 2778 | CHUDAKOV | 1 | 1 | APP | D | EUGENE C | 10-009 | 11-026 | 12-054F | 0 | 2778 | 277800 | 100 | 0 |  |  |  |  |  |  |  |  |  |  |  |  |  |
| 195222195 |  | Assemble Pb Glass Support Structure |  | 698d | 2010-03-01 A | 2012-12-14 A | 195222190 FS-292d | 100% | 2010-03-01 | 2012-12-13 |  | PROCUREMENT>$50K 69 NO ESCALATION | 14,473 | 14473 | CHUDAKOV | 1 | 1 | APP | D | EUGENE C | 10-009 | 11-026 | 12-054F | 0 | 14473 | 1447300 | 100 | 0 |  |  |  |  |  |  |  |  |  |  |  |  |  |
| 195222200 |  | Light Guide Material Procurement |  | 378d | 2010-03-01 A | 2011-08-31 A | 195222195 FS-313d | 100% |  |  |  | PROCUREMENT>$50K 69 NO ESCALATION | 9,062 | 9062 | CHUDAKOV | 1 | 1 | APP | D | EUGENE C | 10-009 | 11-026 | 12-054F | 0 | 9062 | 906200 | 100 | 0 |  |  |  |  |  |  |  |  |  |  |  |  |  |
| 195222205 |  | Glue and Wrap Light Guides |  | 550d | 2010-03-01 A | 2012-05-14 A | 195222200 FS-290d | 100% |  |  |  | PROCUREMENT>$50K 69 NO ESCALATION | 19,254 | 19254 | CHUDAKOV | 1 | 1 | APP | D | EUGENE C | 10-009 | 11-026 | 12-054F | 0 | 19254 | 1925400 | 100 | 0 |  |  |  |  |  |  |  |  |  |  |  |  |  |
| 195222210 |  | Slow Control (procure CAN/ethernet devices) |  | 351d | 2010-03-01 A | 2011-07-25 A | 195222205 FS-497d | 100% |  |  |  | PROCUREMENT>$50K 69 NO ESCALATION | 6,933 | 6933 | CHUDAKOV | 1 | 1 | APP | D | EUGENE C | 10-009 | 11-026 | 12-054F | 0 | 6933 | 693300 | 100 | 0 |  |  |  |  |  |  |  |  |  |  |  |  |  |
| 195222215 |  | Slow Control (procure cables) |  | 592d | 2010-03-01 A | 2012-07-15 A | 195222210 FS-562d | 100% | 2010-03-01 | 2012-07-13 |  | PROCUREMENT>$50K 69 NO ESCALATION | 5,185 | 5185 | CHUDAKOV | 1 | 1 | APP | D | EUGENE C | 10-009 | 11-026 | 12-054F | 0 | 5185 | 518500 | 100 | 0 |  |  |  |  |  |  |  |  |  |  |  |  |  |
| 195222220 |  | Slow Control (assemble and test slow control) |  | 637d | 2010-03-01 A | 2012-09-17 A | 195222215 FS-562d | 100% |  |  |  | PROCUREMENT>$50K 69 NO ESCALATION | 3,120 | 3120 | CHUDAKOV | 1 | 1 | APP | D | EUGENE C | 10-009 | 11-026 | 12-054F | 0 | 3120 | 312000 | 100 | 0 |  |  |  |  |  |  |  |  |  |  |  |  |  |
| 195222225 |  | Final PMT Test (test fixture) |  | 550d | 2010-03-01 A | 2012-05-14 A | 195222220 FS-582d | 100% |  |  |  | PROCUREMENT>$50K 69 NO ESCALATION | 2,722 | 2722 | CHUDAKOV | 1 | 1 | APP | D | EUGENE C | 10-009 | 11-026 | 12-054F | 0 | 2722 | 272200 | 100 | 0 |  |  |  |  |  |  |  |  |  |  |  |  |  |
| 195222230 |  | Final PMT Test (test PMT and bases) |  | 550d | 2010-03-01 A | 2012-05-14 A | 195222225 FS-325d | 100% |  |  |  | PROCUREMENT>$50K 69 NO ESCALATION | 6,239 | 6239 | CHUDAKOV | 1 | 1 | APP | D | EUGENE C | 10-009 | 11-026 | 12-054F | 0 | 6239 | 623900 | 100 | 0 |  |  |  |  |  |  |  |  |  |  |  |  |  |
| 195222235 |  | Final PMT Test (package and shipment) |  | 550d | 2010-03-01 A | 2012-05-14 A | 195222230 FS-540d | 100% |  |  |  | PROCUREMENT>$50K 69 NO ESCALATION | 1,560 | 1560 | CHUDAKOV | 1 | 1 | APP | D | EUGENE C | 10-009 | 11-026 | 12-054F | 0 | 1560 | 156000 | 100 | 0 |  |  |  |  |  |  |  |  |  |  |  |  |  |
| 195222240 |  | Fabricate Optical Cookies (material) |  | 554d | 2010-03-01 A | 2012-05-18 A | 195222235 FS-540d | 100% |  |  |  | PROCUREMENT>$50K 69 NO ESCALATION | 8,331 | 8331 | CHUDAKOV | 1 | 1 | APP | D | EUGENE C | 10-009 | 11-026 | 12-054F | 0 | 8331 | 833100 | 100 | 0 |  |  |  |  |  |  |  |  |  |  |  |  |  |
| 195222245 |  | Fabricate Optical Cookies (cut cookies) |  | 554d | 2010-03-01 A | 2012-05-18 A | 195222240 FS-562d | 100% |  |  |  | PROCUREMENT>$50K 69 NO ESCALATION | 1,757 | 1757 | CHUDAKOV | 1 | 1 | APP | D | EUGENE C | 10-009 | 11-026 | 12-054F | 0 | 1757 | 175700 | 100 | 0 |  |  |  |  |  |  |  |  |  |  |  |  |  |
| 195222250 |  | Fabricate Optical Cookies (Package for shipment) |  | 554d | 2010-03-01 A | 2012-05-18 A | 195222245 FS-582d | 100% |  |  |  | PROCUREMENT>$50K 69 NO ESCALATION | 520 | 520 | CHUDAKOV | 1 | 1 | APP | D | EUGENE C | 10-009 | 11-026 | 12-054F | 0 | 520 | 52000 | 100 | 0 |  |  |  |  |  |  |  |  |  |  |  |  |  |
| 195222255 |  | Cable Refurbishment (locate and acquire cables) |  | 371d | 2010-03-01 A | 2011-08-22 A | 195222250 FS-582d | 100% |  |  |  | PROCUREMENT>$50K 69 NO ESCALATION | 4,902 | 4902 | CHUDAKOV | 1 | 1 | APP | D | EUGENE C | 10-009 | 11-026 | 12-054F | 0 | 4902 | 490200 | 100 | 0 |  |  |  |  |  |  |  |  |  |  |  |  |  |
| 195222260 |  | Cable Refurbishment (procure connectors) |  | 248d | 2010-03-01 A | 2011-02-28 A | 195222255 FS-209d | 100% |  |  |  | PROCUREMENT>$50K 69 NO ESCALATION | 13,749 | 13749 | CHUDAKOV | 1 | 1 | APP | D | EUGENE C | 10-009 | 11-026 | 12-054F | 0 | 13749 | 1374900 | 100 | 0 |  |  |  |  |  |  |  |  |  |  |  |  |  |
| 195222265 |  | Cable Refurbishment (install connectors) |  | 288d | 2010-03-01 A | 2011-04-25 A | 195222260 FS-209d | 100% |  |  |  | PROCUREMENT>$50K 69 NO ESCALATION | 1,560 | 1560 | CHUDAKOV | 1 | 1 | APP | D | EUGENE C | 10-009 | 11-026 | 12-054F | 0 | 1560 | 156000 | 100 | 0 |  |  |  |  |  |  |  |  |  |  |  |  |  |
| 195222270 |  | Cable Refurbishment (package for shipment) |  | 375d | 2010-03-01 A | 2011-08-28 A | 195222265 FS-229d | 100% | 2010-03-01 | 2011-08-26 |  | PROCUREMENT>$50K 69 NO ESCALATION | 520 | 520 | CHUDAKOV | 1 | 1 | APP | D | EUGENE C | 10-009 | 11-026 | 12-054F | 0 | 520 | 52000 | 100 | 0 |  |  |  |  |  |  |  |  |  |  |  |  |  |
| 195222275 |  | Procure Magnetic Sheilds |  | 510d | 2010-03-01 A | 2012-03-19 A | 195222270 FS-229d | 100% |  |  |  | PROCUREMENT>$50K 69 NO ESCALATION | 49,663 | 49663 | CHUDAKOV | 1 | 1 | APP | D | EUGENE C | 10-009 | 11-026 | 12-054F | 0 | 49663 | 4966300 | 100 | 0 |  |  |  |  |  |  |  |  |  |  |  |  |  |
| 195222280 |  | Procure Shipping Materials |  | 700d | 2010-03-01 A | 2012-12-16 A | 195222275 FS-582d | 100% | 2010-03-01 | 2012-12-17 |  | PROCUREMENT>$50K 69 NO ESCALATION | 13,396 | 13396 | CHUDAKOV | 1 | 1 | APP | D | EUGENE C | 10-009 | 11-026 | 12-054F | 0 | 13396 | 1339600 | 100 | 0 |  |  |  |  |  |  |  |  |  |  |  |  |  |
| 195222285 |  | Shipping to Jlab |  | 714d | 2010-03-01 A | 2013-07-15 A | 195222280 FS-431.5d | 100% | 2010-03-01 | 2013-01-14 |  | PROCUREMENT>$50K 69 NO ESCALATION | 9,189 | 9189 | CHUDAKOV | 1 | 1 | APP | D | EUGENE C | 10-009 | 11-026 | 12-054F | 0 | 9189 | 918900 | 100 | 918.9 |  | XX |  |  |  |  |  |  |  |  |  |  |  |
| 195222015M |  | Readiness Review | milestone | 0d | 2010-06-21 A | 2010-06-21 A | 195222010 | 100% | 2010-07-30 | 2010-07-30 |  |  |  | 0 | CHUDAKOV | 1 | 1 | APP | M | EUGENE C | 10-009 | 11-026 | 12-054F |  |  |  |  |  |  |  |  |  |  |  |  |  |  |  |  |  |  |
| 195222120M |  | Jlab Reveiw and Approval of Base Circuit Design | milestone | 0d | 2010-10-25 A | 2010-10-25 A | 195222115 FS-8d | 100% | 2010-11-01 | 2010-11-01 |  |  |  | 0 | CHUDAKOV | 1 | 1 | APP | M | EUGENE C | 10-009 | 11-026 | 12-054F |  |  |  |  |  |  |  |  |  |  |  |  |  |  |  |  |  |  |
| 195222180M |  | Jlab Reveiw and Approval of Support Drawings | milestone | 0d | 2011-07-01 A | 2011-07-01 A | 195222175 SS | 100% | 2011-08-01 | 2011-08-01 |  |  |  | 0 | CHUDAKOV | 1 | 1 | APP | M | EUGENE C | 10-009 | 11-026 | 12-054F |  |  |  |  |  |  |  |  |  |  |  |  |  |  |  |  |  |  |
| 195222290 |  | Re-Baseline Actuals Adjustment |  | 1d | 2013-08-30 A | 2013-08-30 A |  | 100% | 2013-09-03 | 2013-09-03 |  | PROCUREMENT>$50K 69 NO ESCALATION | -8,558.26 |  |  |  |  |  |  |  |  |  |  |  |  |  | 100 |  |  |  | ADJ |  |  |  |  |  |  |  |  |  |  |
| 295222000 |  | Indiana Contract Completion |  | 43d | 2013-09-03 A | 2013-09-23 A | 9-130M FS+228d | 100% | 2013-10-01 | 2013-12-02 | 8/5 M-F w/JLAB Holidays ReBaseline | PROCUREMENT>$50K 69 NO ESCALATION | 8,558.26 | 0 | CHUDAKOV | 1 | 1 |  | D | EUGENE C |  | 11-026 | 12-054F | 0 | 8558.26 | 855826 | 100 |  |  |  |  | 295212260 | 8558.26 | D | 10-046 | 11-006 | 13-007F | OB | 13-015 | PR | OB |

| ID | WBS | Activity | Type | Duration | Start | Finish | Predecessors | Complete | Planned start | Planned finish | Calendar | Resources | Cost | Actual cost | MONTHLY EV COST | ReBaseline Actuals Adjustment | RESP - Responsibility | STRT%COMP for CM EVM | FNSH%COMP for CM EVM | Advance Purchase Plan > 500K | EVMS Reporting Codes | CAM RESPONSIBLE | 12 GEV MAJOR PROCUREMENT CATAGORY | CR 11-016 | CR 11-VA3 | CR 12-015 | Remaining Material Cost Based on % Compl | Claimed Material Cost Based on % Complet | Initial Claimed Material Calc | Claimed Material Divider | Calculated Remaining Total Cost | HALL D Related Milestones | CR 11-001 | LOE % Pre Calc | LOE % | LOE Divider | LOE Multiplier | Phil Dev | CR 10-001 | CR 11-006 | CR 11-026 | CR 12-054 | Activities with Steps | Original Activity ID Rebaseline | CR 10-046 | CR 13-007 | BOE Procurement | CR 13-015 | Post Rebaseline | Obligated Prior to Rebaseline |
| --- | --- | --- | --- | --- | --- | --- | --- | --- | --- | --- | --- | --- | --- | --- | --- | --- | --- | --- | --- | --- | --- | --- | --- | --- | --- | --- | --- | --- | --- | --- | --- | --- | --- | --- | --- | --- | --- | --- | --- | --- | --- | --- | --- | --- | --- | --- | --- | --- | --- | --- |
|  | 4 | **1.9.5.2.4 HALL D DETECTOR SUPPORT** |  |  | 2013-08-30 | 2013-08-30 |  |  |  |  |  |  |  |  |  |  |  |  |  |  |  |  |  |  |  |  |  |  |  |  |  |  |  |  |  |  |  |  |  |  |  |  |  |  |  |  |  |  |  |  |
| 19524000 |  | Re-Baseline Actuals Adjustment |  | 1d | 2013-08-30 A | 2013-08-30 A |  | 100% | 2013-09-03 | 2013-09-03 |  | PROCUREMENT>$50K 69 NO ESCALATION |  |  | 0 | ADJ |  |  |  |  |  |  |  |  |  |  |  |  |  |  |  |  |  |  |  |  |  |  |  |  |  |  |  |  |  |  |  |  |  |  |
|  | 6 | **1.9.6 12 GeV ACCEL BUILDINGS** |  |  | 2010-12-01 | 2013-08-30 |  |  |  |  |  |  |  |  |  |  |  |  |  |  |  |  |  |  |  |  |  |  |  |  |  |  |  |  |  |  |  |  |  |  |  |  |  |  |  |  |  |  |  |  |
|  | 1 | **1.9.6.1 12 GeV N&S ACCESS LCW UPGRADES** |  |  | 2010-12-01 | 2013-08-30 |  |  |  |  |  |  |  |  |  |  |  |  |  |  |  |  |  |  |  |  |  |  |  |  |  |  |  |  |  |  |  |  |  |  |  |  |  |  |  |  |  |  |  |  |
| 1961000 |  | N&S Access LCW Upgrades Constrctn Contract Progress December 2010 |  | 17d | 2010-12-01 A | 2010-12-30 A | 9-110M FS+41d | 100% |  |  |  |  |  |  | 0 |  | WHITLATCH C | 1 | 1 | APP | C | REBECCA Y | 6112 | 11-016 | 11-VA3 | 12-015 |  |  |  |  |  |  |  |  |  |  |  |  |  |  |  |  |  |  |  |  |  |  |  |  |
| 1961000a |  | N&S Access LCW Upgrades Constrctn Contract Progress January 2011 |  | 37d | 2010-12-01 A | 2011-01-31 A | 1961000 FS-17d | 100% |  |  |  |  |  |  | 0 |  | WHITLATCH C | 1 | 1 | APP | C | REBECCA Y | 6112 | 11-016 | 11-VA3 | 12-015 |  |  |  |  |  |  |  |  |  |  |  |  |  |  |  |  |  |  |  |  |  |  |  |  |
| 1961000b |  | N&S Access LCW Upgrades Constrctn Contract Progress February 2011 |  | 56d | 2010-12-01 A | 2011-02-28 A | 1961000a FS-37d | 100% |  |  |  |  |  |  | 0 |  | WHITLATCH C | 1 | 1 | APP | C | REBECCA Y | 6112 | 11-016 | 11-VA3 | 12-015 |  |  |  |  |  |  |  |  |  |  |  |  |  |  |  |  |  |  |  |  |  |  |  |  |
| 1961000c |  | N&S Access LCW Upgrades Constrctn Contract Progress March 2011 |  | 75d | 2010-12-01 A | 2011-03-25 A | 1961000b FS-56d | 100% |  |  |  | PROCUREMENT<$50K 60 NO ESCALATION; PROCUREMENT>$50K 69 NO ESCALATION | 184,600 |  | 184600 |  | WHITLATCH C | 1 | 1 | APP | C | REBECCA Y | 6112 | 11-016 | 11-VA3 | 12-015 | 0 | 184600 | 18460000 | 100 | 0 |  |  |  |  |  |  |  |  |  |  |  |  |  |  |  |  |  |  |  |
| 1961000d |  | N&S Access LCW Upgrades Constrctn Contract Progress April 2011 |  | 75d | 2010-12-01 A | 2011-03-25 A | 1961000c FS-79d | 100% |  |  |  | PROCUREMENT>$50K 69 NO ESCALATION | 844,600 |  | 844600 |  | WHITLATCH C | 1 | 1 | APP | C | REBECCA Y | 6112 | 11-016 | 11-VA3 | 12-015 | 0 | 844600 | 84460000 | 100 | 0 |  |  |  |  |  |  |  |  |  |  |  |  |  |  |  |  |  |  |  |
| 1961000f |  | N&S Access LCW Upgrades Constrctn Contract Progress May 2011 |  | 100d | 2010-12-01 A | 2011-04-29 A | 1961000d FS-100d | 100% |  |  |  | PROCUREMENT>$50K 69 NO ESCALATION | 1,106,800 |  | 1106800 |  | WHITLATCH C | 1 | 1 | APP | C | REBECCA Y | 6112 | 11-016 | 11-VA3 | 12-015 | 0 | 1106800 | 110680000 | 100 | 0 |  |  |  |  |  |  |  |  |  |  |  |  |  |  |  |  |  |  |  |
| 1961000g |  | N&S Access LCW Upgrades Constrctn Contract Progress June 2011 |  | 143d | 2010-12-01 A | 2011-06-30 A | 1961000f FS-121d | 100% |  |  |  | PROCUREMENT>$50K 69 NO ESCALATION | 420,200 |  | 420200 |  | WHITLATCH C | 1 | 1 | APP | C | REBECCA Y | 6112 | 11-016 | 11-VA3 | 12-015 | 0 | 420200 | 42020000 | 100 | 0 |  |  |  |  |  |  |  |  |  |  |  |  |  |  |  |  |  |  |  |
| 1961000h |  | N&S Access LCW Upgrades Constrctn Contract Progress July 2011 |  | 143d | 2010-12-01 A | 2011-06-30 A | 1961000g FS-143d | 100% |  |  |  | PROCUREMENT>$50K 69 NO ESCALATION | 227,100 |  | 227100 |  | WHITLATCH C | 1 | 1 | APP | C | REBECCA Y | 6112 | 11-016 | 11-VA3 | 12-015 | 0 | 227100 | 22710000 | 100 | 0 |  |  |  |  |  |  |  |  |  |  |  |  |  |  |  |  |  |  |  |
| 1961000j |  | N&S Access LCW Upgrades Constrctn Contract Progress August 2011 |  | 143d | 2010-12-01 A | 2011-06-30 A | 1961000h FS-163d | 100% |  |  |  | PROCUREMENT>$50K 69 NO ESCALATION | 239,000 |  | 239000 |  | WHITLATCH C | 1 | 1 | APP | C | REBECCA Y | 6112 | 11-016 | 11-VA3 | 12-015 | 0 | 239000 | 23900000 | 100 | 0 |  |  |  |  |  |  |  |  |  |  |  |  |  |  |  |  |  |  |  |
| 1961000k |  | N&S Access LCW Upgrades Constrctn Contract Progress September 2011 |  | 207d | 2010-12-01 A | 2011-09-30 A | 1961000j FS-186d | 100% |  |  |  | PROCUREMENT>$50K 69 NO ESCALATION | 205,700 |  | 205700 |  | WHITLATCH C | 1 | 1 | APP | C | REBECCA Y | 6112 | 11-016 | 11-VA3 | 12-015 | 0 | 205700 | 20570000 | 100 | 0 |  |  |  |  |  |  |  |  |  |  |  |  |  |  |  |  |  |  |  |
| 1961000n |  | N&S Access LCW Upgrades Constrctn Contract Progress October 2011 |  | 222d | 2010-12-01 A | 2011-10-21 A | 1961000k FS-207d | 100% |  |  |  | PROCUREMENT>$50K 69 NO ESCALATION | 58,000 |  | 58000 |  | WHITLATCH C | 1 | 1 | APP | C | REBECCA Y | 6112 | 11-016 | 11-VA3 | 12-015 | 0 | 58000 | 5800000 | 100 | 0 |  |  |  |  |  |  |  |  |  |  |  |  |  |  |  |  |  |  |  |
| 1961005 |  | N&S Access LCW Upgrades Contract Modifications |  | 248d | 2010-12-01 A | 2011-11-30 A | 9-110M FS+41d | 100% |  |  |  | PROCUREMENT>$50K 69 NO ESCALATION | 164,000 |  | 164000 |  | WHITLATCH C | 1 | 1 | APP | C | REBECCA Y | 6112 | 11-016 | 11-VA3 | 12-015 | 0 | 164000 | 16400000 | 100 | 0 |  |  |  |  |  |  |  |  |  |  |  |  |  |  |  |  |  |  |  |
| 1961010 |  | Re-Baseline Actuals Adjustment |  | 1d | 2013-08-30 A | 2013-08-30 A |  | 100% | 2013-09-03 | 2013-09-03 |  | PROCUREMENT>$50K 69 NO ESCALATION | -25,739.57 |  |  | ADJ |  |  |  |  |  |  |  |  |  |  |  |  |  | 100 |  |  |  |  |  |  |  |  |  |  |  |  |  |  |  |  |  |  |  |  |
|  | 7 | **1.9.7 12 Gev Infastructure** |  |  | 2010-10-01 | 2013-10-21 |  |  |  |  |  |  |  |  |  |  |  |  |  |  |  |  |  |  |  |  |  |  |  |  |  |  |  |  |  |  |  |  |  |  |  |  |  |  |  |  |  |  |  |  |
|  | 1 | **1.9.7.1 12 Gev Misc Infastructure** |  |  | 2010-10-01 | 2013-10-21 |  |  |  |  |  |  |  |  |  |  |  |  |  |  |  |  |  |  |  |  |  |  |  |  |  |  |  |  |  |  |  |  |  |  |  |  |  |  |  |  |  |  |  |  |
| 197111060 |  | Blue Crab Lease October-2010 |  | 21d | 2010-10-01 A | 2010-10-29 A | 9-110M | 100% |  |  |  | PROCUREMENT<$50K 60 NO ESCALATION; PROCUREMENT>$50K 69 NO ESCALATION | 34,702.89 |  | 34702.89 |  | CHUDAKOV | 1 | 1 |  | H | EUGENE C |  |  |  |  | 0 | 34702.89 | 3470289 | 100 | 0 | D | 11-1VA |  |  |  |  |  |  |  |  |  |  |  |  |  |  |  |  |  |
| 197111065 |  | Blue Crab Lease |  | 717d | 2010-10-01 A | 2013-08-22 A | 197111060 FS-21d | 100% |  |  |  | PROCUREMENT>$50K 69 NO ESCALATION; PROCUREMENT<$50K 60 NO ESCALATION | 235,254.99 |  | 235254.99 |  | CHUDAKOV | 1 | 1 |  | E | EUGENE C |  |  |  |  | 0 | 235254.99 | 23525499 | 100 | 5246.186277 | D | 11-1VA | 2.23152022 | 97.76847977 | 100 | 100 | MP |  |  |  |  |  |  |  |  |  |  |  |  |
| 197111080 |  | Blue Crab Utilities October-2010 |  | 21d | 2010-10-01 A | 2010-10-29 A | 9-110M | 100% |  |  |  | PROCUREMENT>$50K 69 NO ESCALATION | 2,051.51 |  | 2051.51 |  | CHUDAKOV | 1 | 1 |  | H | EUGENE C |  |  |  |  | 0 | 2051.51 | 205151 | 100 | 0 | D | 11-1VA |  |  |  |  |  |  |  |  |  |  |  |  |  |  |  |  |  |
| 197111085 |  | Blue Crab Utilities |  | 717d | 2010-10-01 A | 2013-08-22 A | 197111080 FS-21d | 100% |  |  |  | PROCUREMENT>$50K 69 NO ESCALATION | 57,948.49 |  | 57948.49 |  | CHUDAKOV | 1 | 1 |  | E | EUGENE C |  |  |  |  | 0 | 57948.49 | 5794849 | 100 | 1292.251327 | D | 11-1VA | 2.23152022 | 97.76847977 | 100 | 100 | MP |  |  |  |  |  |  |  |  |  |  |  |  |
| 197111100 |  | Blue Crab Fork Lift-2010 |  | 21d | 2010-10-01 A | 2010-10-29 A | 9-110M | 100% |  |  |  | PROCUREMENT>$50K 69 NO ESCALATION | 4,685.2 |  | 4685.2 |  | CHUDAKOV | 1 | 1 |  | E | EUGENE C |  |  |  |  | 0 | 4685.2 | 468520 | 100 | 0 | D | 11-1VA |  |  | 100 | 100 |  |  |  |  |  |  |  |  |  |  |  |  |  |
| 197111105 |  | Blue Crab Fork Lift-FY11/12 |  | 368d | 2010-10-01 A | 2012-03-30 A | 197111100 FS-21d | 100% |  |  |  | PROCUREMENT>$50K 69 NO ESCALATION | 27,378 |  | 27378 |  | CHUDAKOV | 1 | 1 |  | E | EUGENE C |  |  |  |  | 0 | 27378 | 2737800 | 100 | 0 | D | 11-1VA | 5.97826086 | 94.02173913 | 100 | 100 |  |  |  |  |  |  |  |  |  |  |  |  |  |
| 197111110 |  | Blue Crab Shelving |  | 21d | 2010-10-01 A | 2010-10-29 A | 9-110M | 100% |  |  |  | PROCUREMENT>$50K 69 NO ESCALATION | 36,648.53 |  | 36648.53 |  | CHUDAKOV | 1 | 1 |  | H | EUGENE C |  |  |  |  | 0 | 36648.53 | 3664853 | 100 | 0 | D | 11-1VA |  |  |  |  |  |  |  |  |  |  |  |  |  |  |  |  |  |
| 197111115 |  | Blue Crab Janitorial October-2010 |  | 21d | 2010-10-01 A | 2010-10-29 A | 9-110M | 100% |  |  |  | SUPPLIES & MATERIALS | 240.36 |  | 240.36 |  | CHUDAKOV | 1 | 1 |  | H | EUGENE C |  |  |  |  |  |  |  |  | 0 | D | 11-1VA |  |  |  |  |  |  |  |  |  |  |  |  |  |  |  |  |  |
| 197111001M |  | Space rented for Chamber Work | milestone | 0d | 2010-11-01 A | 2010-11-01 A | 9-100M FS+205d | 100% | 2010-12-01 | 2010-12-01 |  |  |  |  | 0 |  | CHUDAKOV | 1 | 1 |  | M | EUGENE C |  |  |  |  |  |  |  |  |  | D |  |  |  |  |  |  | 10-1VA | 11-006 | 11-026 | 12-054F |  |  |  |  |  |  |  |  |
| 197111005 |  | Procure 2000 Sq. Ft. CLASS 10,000 Clean Room |  | 56d | 2010-11-01 A | 2011-01-28 A | 9-100M FS+184d | 100% |  |  |  | PROCUREMENT>$50K 69 NO ESCALATION FY11; PROCUREMENT<$50K 60 NO ESCALATION FY11 | 250,000 |  | 250000 |  | CHUDAKOV | 1 | 1 |  | S | EUGENE C |  |  |  |  | 0 | 250000 | 25000000 | 100 | 0 | D |  |  |  |  |  |  | 10-1VA | 11-006 | 11-026 | 12-054F | ST |  |  |  |  |  |  |  |
| 197111010 |  | Procure HVAC Unit |  | 19d | 2010-11-01 A | 2010-11-29 A | 9-100M FS+184d | 100% |  |  |  | PROCUREMENT<$50K 60; PROCUREMENT>$50K 69 | 90,000 |  | 90000 |  | CHUDAKOV | 1 | 1 |  | D | EUGENE C |  |  |  |  | 0 | 90000 | 9000000 | 100 | 0 | D |  |  |  |  |  |  | 10-1VA | 11-006 | 11-026 | 12-054F |  |  |  |  |  |  |  |  |
| 197111055 |  | Blue Crab Phone Lines FY11 |  | 248d | 2010-11-01 A | 2011-10-31 A | 197111045 FS-20d | 100% |  |  |  | PROCUREMENT<$50K 60 NO ESCALATION | 1,836 |  | 1836 |  | CHUDAKOV | 1 | 1 |  | E | EUGENE C |  |  |  |  | 0 | 1836 | 183600 | 100 | 0 | D | 11-1VA | 8.46774193 | 91.53225806 | 100 | 100 |  |  |  |  |  |  |  |  |  |  |  |  |  |
| 197111015 |  | Install HVAC Unit |  | 41d | 2010-11-22 A | 2011-01-28 A | 197111010 | 100% |  |  |  | MECH TECH [251.6 h] | 10,836.41 | 10,836.41 | 10501.784 |  | CHUDAKOV | 1 | 1 |  | H | EUGENE C |  |  |  |  |  |  |  |  | 0 | D |  |  |  |  |  |  | 10-1VA | 11-006 | 11-026 | 12-054F |  |  |  |  |  |  |  |  |
| 197111020 |  | Modify Building Electrical Distribution FY10 |  | 37d | 2010-11-30 A | 2011-01-28 A | 197111001M | 100% |  |  |  | ELEC TECH [506.06 h] | 21,644.19 | 21,644.19 | 20976.187 |  | CHUDAKOV | 1 | 1 |  | H | EUGENE C |  |  |  |  |  |  |  |  | 0 | D | 11-001 |  |  |  |  |  | 10-1VA | 11-006 | 11-026 | 12-054F |  |  |  |  |  |  |  |  |
| 197111020a |  | Modify Building Electrical Distribution FY11 |  | 37d | 2010-11-30 A | 2011-01-28 A | 197111020 FS-50d | 100% |  |  |  | ELEC TECH [247.14 h] | 10,570.18 | 10,570.18 | 10570.1778 |  | CHUDAKOV | 1 | 1 |  | H | EUGENE C |  |  |  |  |  |  |  |  | 0 | D | 11-001 |  |  |  |  |  | 10-1VA | 11-006 | 11-026 | 12-054F |  |  |  |  |  |  |  |  |
| 197111135 |  | Blue Crab Misc. Supplies FY11 |  | 207d | 2010-12-01 A | 2011-09-30 A | 9-110M FS+41d | 100% |  |  |  | SUPPLIES & MATERIALS | 77,399.52 |  | 77399.52 |  | CHUDAKOV | 1 | 1 |  | E | EUGENE C |  |  |  |  |  |  |  |  | 0 | D | 11-1VA | 10.14492753 | 89.85507246 | 100 | 100 |  |  |  |  |  |  |  |  |  |  |  |  |  |
| 197111045 |  | Blue Crab Phone Lines Upfront Costs |  | 18d | 2011-01-01 A | 2011-01-28 A | 9-110M FS+21d | 100% | 2011-01-04 | 2011-01-28 |  | SUPPLIES & MATERIALS | 1,015 |  | 1015 |  | CHUDAKOV | 1 | 1 |  | H | EUGENE C |  |  |  |  |  |  |  |  | 0 | D | 11-1VA |  |  |  |  |  |  |  |  |  |  |  |  |  |  |  |  |  |
| 197111120 |  | Blue Crab Janitorial FY11 |  | 189d | 2011-01-03 A | 2011-09-30 A | 197111115 FS+38d | 100% | 2011-01-04 | 2011-09-30 |  | SUPPLIES & MATERIALS | 1,365 |  | 1365 |  | CHUDAKOV | 1 | 1 |  | E | EUGENE C |  |  |  |  |  |  |  |  | 0 | D | 11-1VA | 11.11111111 | 88.88888888 | 100 | 100 |  |  |  |  |  |  |  |  |  |  |  |  |  |
| 197111030M |  | Space Ready | milestone | 0d | 2011-01-28 A | 2011-01-28 A | 197111015, 197111005, 197111020a | 100% | 2011-03-03 | 2011-03-03 |  |  |  |  | 0 |  | CHUDAKOV | 1 | 1 |  | M | EUGENE C |  |  |  |  |  |  |  |  |  | D |  |  |  |  |  |  | 10-1VA | 11-006 | 11-026 | 12-054F |  |  |  |  |  |  |  |  |
| 197111125 |  | Blue Crab Janitorial FY12 |  | 247d | 2011-10-03 A | 2012-09-28 A | 197111120 | 100% |  |  |  | SUPPLIES & MATERIALS | 1,878.06 |  | 1878.06 |  | CHUDAKOV | 1 | 1 |  | E | EUGENE C |  |  |  |  |  |  |  |  | 0 | D | 11-1VA | 7.69230769 | 92.3076923 | 100 | 100 |  |  |  |  |  |  |  |  |  |  |  |  |  |
| 197111140 |  | Blue Crab Misc. Supplies FY12 |  | 247d | 2011-10-03 A | 2012-09-28 A | 197111135 | 100% |  |  |  | SUPPLIES & MATERIALS | 51,595 |  | 51595 |  | CHUDAKOV | 1 | 1 |  | E | EUGENE C |  |  |  |  |  |  |  |  | 0 | D | 11-1VA | 7.69230769 | 92.3076923 | 100 | 100 |  |  |  |  |  |  |  |  |  |  |  |  |  |
| 197111058 |  | Blue Crab Phone Lines FY12 |  | 226d | 2011-11-01 A | 2012-09-28 A | 197111055 | 100% |  |  |  | SUPPLIES & MATERIALS | 1,736.69 |  | 1736.69 |  | CHUDAKOV | 1 | 1 |  | E | EUGENE C |  |  |  |  |  |  |  |  | 0 | D | 11-1VA | 8.40707964 | 91.59292035 | 100 | 100 |  |  |  |  |  |  |  |  |  |  |  |  |  |
| 197111059 |  | Blue Crab Phone Lines FY13 |  | 222d | 2012-10-01 A | 2013-08-22 A | 197111058 | 100% |  |  |  | SUPPLIES & MATERIALS | 1,792.09 |  | 1792.09 |  | CHUDAKOV | 1 | 1 |  | E | EUGENE C |  |  |  |  |  |  |  |  | 129.209689 | D | 11-1VA | 7.2072072 | 92.79279279 | 100 | 100 |  |  |  |  |  |  |  |  |  |  |  |  |  |
| 197111130 |  | Blue Crab Janitorial FY13 |  | 164d | 2012-10-01 A | 2013-05-31 A | 197111125 | 100% |  |  |  | SUPPLIES & MATERIALS | 1,304.4 |  | 1304.4 |  | CHUDAKOV | 1 | 1 |  | E | EUGENE C |  |  |  |  |  |  |  |  | 0 | D | 11-1VA | 13.41463414 | 86.58536585 | 100 | 100 |  |  |  |  |  |  |  |  |  |  |  |  |  |
| 197111145 |  | Blue Crab Misc. Supplies FY13 |  | 222d | 2012-10-01 A | 2013-08-22 A | 197111140 | 100% |  |  |  | SUPPLIES & MATERIALS | 26,620.44 |  | 26620.44 |  | CHUDAKOV | 1 | 1 |  | E | EUGENE C |  |  |  |  |  |  |  |  | 1919.333724 | D | 11-1VA | 7.2072072 | 92.79279279 | 100 | 100 |  |  |  |  |  |  |  |  |  |  |  |  |  |
| 197111150 |  | Re-Baseline Actuals Adjustment |  | 1d | 2013-08-30 A | 2013-08-30 A |  | 100% | 2013-09-03 | 2013-09-03 |  | PROCUREMENT>$50K 69 NO ESCALATION | -19,991.49 |  |  | ADJ |  |  |  |  |  |  |  |  |  |  |  |  |  | 100 |  |  |  |  |  |  |  |  |  |  |  |  |  |  |  |  |  |  |  |  |
| 2971000 |  | Blue Crab Cleanroom Completion |  | 43d | 2013-09-03 A | 2013-10-21 A | 295212255 FS-43d | 100% | 2013-10-01 | 2013-12-02 | 8/5 M-F w/JLAB Holidays ReBaseline | PROCUREMENT>$50K 69 NO ESCALATION | 29,009.92 |  | 29009.92 |  | CHUDAKOV | 1 | 1 |  | D | EUGENE C |  |  |  |  | 0 | 29009.92 | 2900992 | 100 |  | D |  |  |  |  |  |  |  | 11-006 | 11-026 | 12-054F |  | 295212260 | 10-046 | 13-007F | OB | 13-015 | PR | OB |

Notes:
- 197111005: Steps: Engineering Shop drawings and submittals (done); Delivery of Clean Room and Materials (done); Installation of Clean Room and Materials (done); Delivery of FFUs and Hepa Filters (done); Installation of FFUs and Hepa Filters (done); Delivery of Fire Protection (done); Installation of Fire Protection (done); Start-up, Commisioning, Test , Balance and Certification (done)

| ID | WBS | Activity | Duration | Start | Finish | Predecessors | Complete | Planned start | Planned finish | Resources | Cost | Remaining Material Cost Based on % Compl | Claimed Material Cost Based on % Complet | Initial Claimed Material Calc | Claimed Material Divider | Calculated Remaining Total Cost | MONTHLY EV COST | RESP - Responsibility | STRT%COMP for CM EVM | FNSH%COMP for CM EVM | Advance Purchase Plan > 500K | EVMS Reporting Codes | CAM RESPONSIBLE | CR 10-011 | CR 10-014 | CR 08-016 | CR 09-012 | CR 09-022 | CR 10-069 | CR 11-026 | CR 11-046 |
| --- | --- | --- | --- | --- | --- | --- | --- | --- | --- | --- | --- | --- | --- | --- | --- | --- | --- | --- | --- | --- | --- | --- | --- | --- | --- | --- | --- | --- | --- | --- | --- |
|  | 10 | **1.10 NON DOE SCOPE** |  | 2009-12-01 | 2013-06-21 |  |  |  |  |  |  |  |  |  |  |  |  |  |  |  |  |  |  |  |  |  |  |  |  |  |  |
|  | 2 | **1.10.2 HALL B NSF-FUNDED DETECTORS** |  | 2009-12-01 | 2010-10-25 |  |  |  |  |  |  |  |  |  |  |  |  |  |  |  |  |  |  |  |  |  |  |  |  |  |  |
|  | 2 | **1.10.2.2 HALL B NSF-FUNDED DETECTORS-CALORIMETERS** |  | 2009-12-01 | 2010-10-25 |  |  |  |  |  |  |  |  |  |  |  |  |  |  |  |  |  |  |  |  |  |  |  |  |  |  |
|  | 3 | **1.10.2.2.3 NSF-MRI ACTIVITIES FOR CLAS 12 PRESHOWER CALORIMETER** |  | 2009-12-01 | 2010-10-25 |  |  |  |  |  |  |  |  |  |  |  |  |  |  |  |  |  |  |  |  |  |  |  |  |  |  |
|  | 1 | **1.10.2.2.3.1 WAVELENGTH SHIFTING FIBERS** |  | 2010-02-01 | 2010-10-25 |  |  |  |  |  |  |  |  |  |  |  |  |  |  |  |  |  |  |  |  |  |  |  |  |  |  |
| 1102231000 |  | Placeholder NSF Wavelength Shifting Fiber Procurement | 187d | 2010-02-01 A | 2010-10-25 A | 9-100M FS+41d | 100% |  |  | PROCUREMENT>$50K 69 | 120,000 | 0 | 120000 | 12000000 | 100 | 0 | 120000 | ELOUADRHIRI L | 1 | 1 | APP | D | LATIFA E | 10-011 | 10-014 |  |  |  |  |  |  |
|  | 2 | **1.10.2.2.3.2 PMT SYSTEM** |  | 2009-12-01 | 2010-09-30 |  |  |  |  |  |  |  |  |  |  |  |  |  |  |  |  |  |  |  |  |  |  |  |  |  |  |
|  | 1 | **1.10.2.2.3.2.1 PHOTOMULTIPLIER TUBES** |  | 2009-12-01 | 2009-12-21 |  |  |  |  |  |  |  |  |  |  |  |  |  |  |  |  |  |  |  |  |  |  |  |  |  |  |
| 11022321000 |  | Placeholder NSF Photomultiplier Tube Procurement | 14d | 2009-12-01 A | 2009-12-21 A | 9-100M FS+41d | 100% | 2009-12-01 | 2009-12-18 | PROCUREMENT>$50K 69 | 218,000 | 0 | 218000 | 21800000 | 100 | 0 | 218000 | ELOUADRHIRI L | 1 | 1 | APP | D | LATIFA E | 10-011 | 10-014 |  |  |  |  |  |  |
|  | 2 | **1.10.2.2.3.2.2 MU-METAL SHIELDS** |  | 2010-02-01 | 2010-09-30 |  |  |  |  |  |  |  |  |  |  |  |  |  |  |  |  |  |  |  |  |  |  |  |  |  |  |
| 11022322000 |  | Placeholder NSF Mu-Metal Shield Procurement | 170d | 2010-02-01 A | 2010-09-30 A | 9-100M FS+41d | 100% |  |  | PROCUREMENT>$50K 69 | 18,000 | 0 | 18000 | 1800000 | 100 | 0 | 18000 | ELOUADRHIRI L | 1 | 1 | APP | D | LATIFA E | 10-011 | 10-014 |  |  |  |  |  |  |
|  | 3 | **1.10.2.2.3.2.3 HIGH VOLTAGE CABLES** |  | 2009-12-01 | 2009-12-21 |  |  |  |  |  |  |  |  |  |  |  |  |  |  |  |  |  |  |  |  |  |  |  |  |  |  |
| 11022323000 |  | Placeholder NSF High Voltage Cable Procurement | 14d | 2009-12-01 A | 2009-12-21 A | 9-100M FS+41d | 100% | 2009-12-01 | 2009-12-18 | PROCUREMENT>$50K 69 | 59,000 | 0 | 59000 | 5900000 | 100 | 0 | 59000 | ELOUADRHIRI L | 1 | 1 | APP | D | LATIFA E | 10-011 | 10-014 |  |  |  |  |  |  |
|  | 4 | **1.10.2.2.3.2.4 SIGNAL SPLITTERS** |  | 2009-12-01 | 2009-12-21 |  |  |  |  |  |  |  |  |  |  |  |  |  |  |  |  |  |  |  |  |  |  |  |  |  |  |
| 11022324000 |  | Placeholder NSF Signal Splitters Procurement | 14d | 2009-12-01 A | 2009-12-21 A | 9-100M FS+41d | 100% | 2009-12-01 | 2009-12-18 | PROCUREMENT>$50K 69 | 27,000 | 0 | 27000 | 2700000 | 100 | 0 | 27000 | ELOUADRHIRI L | 1 | 1 | APP | D | LATIFA E | 10-011 | 10-014 |  |  |  |  |  |  |
|  | 5 | **1.10.2.2.3.2.5 ELECTRONICS CABLES** |  | 2010-02-01 | 2010-02-26 |  |  |  |  |  |  |  |  |  |  |  |  |  |  |  |  |  |  |  |  |  |  |  |  |  |  |
| 11022325000 |  | Placeholder NSF Electronics Cables Procurement | 19d | 2010-02-01 A | 2010-02-26 A | 9-100M FS+41d | 100% |  |  | PROCUREMENT>$50K 69 | 42,000 | 0 | 42000 | 4200000 | 100 | 0 | 42000 | ELOUADRHIRI L | 1 | 1 | APP | D | LATIFA E | 10-011 | 10-014 |  |  |  |  |  |  |
|  | 3 | **1.10.3 HALL C NSERC-FUNDED DETECTORS** |  | 2010-10-01 | 2013-06-21 |  |  |  |  |  |  |  |  |  |  |  |  |  |  |  |  |  |  |  |  |  |  |  |  |  |  |
|  | 2 | **1.10.3.2 HALL C NSERC-FUNDED DETECTORS- HEAVY GAS CERENKOV** |  | 2010-10-01 | 2013-06-21 |  |  |  |  |  |  |  |  |  |  |  |  |  |  |  |  |  |  |  |  |  |  |  |  |  |  |
|  | 4 | **1.10.3.2.4 HALL C NSERC-FUNDED-HEAVY GAS CERENKOV** |  | 2010-10-01 | 2013-06-21 |  |  |  |  |  |  |  |  |  |  |  |  |  |  |  |  |  |  |  |  |  |  |  |  |  |  |
| 110324000 |  | Fab Heavy Gas Cerenkov | 674d | 2010-10-01 A | 2013-06-21 A | 9-110M | 100% |  |  | PROCUREMENT<$50K 60 NO ESCALATION | 125,000 | 0 | 125000 | 12500000 | 100 | 0 | 125000 | FENKER H | 1 | 1 |  | D | HOWARD F |  |  | 08-016 | 09-012 | 09-022 | 10-069 | 11-026 | 11-046 |

## Activity codes

| Code | Value | Meaning |
| --- | --- | --- |
| 12 GEV MAJOR PROCUREMENT CATAGORY | 3111A | VENDOR FAB - WAVEGUIDES LOT #1&2 1-88 |
| 12 GEV MAJOR PROCUREMENT CATAGORY | 3111B | VENDOR FAB - NIOBIUM LOT #1, 2 & 3 |
| 12 GEV MAJOR PROCUREMENT CATAGORY | 3111C | VENDOR FAB - CAVITY FAB LOT #1, 2 & 3 |
| 12 GEV MAJOR PROCUREMENT CATAGORY | 3112A | VENDOR FAB - SPACE FRAMES LOT #1, 2 & 3 |
| 12 GEV MAJOR PROCUREMENT CATAGORY | 3112B | VENDOR FAB - COLD TUNERS LOT #1, 2 & 3 |
| 12 GEV MAJOR PROCUREMENT CATAGORY | 3112C | VENDOR FAB - WARM TUNERS LOT #1, 2 & 3 |
| 12 GEV MAJOR PROCUREMENT CATAGORY | 3113A | VENDOR FAB - END CANS LOT #1, 2 & 3 |
| 12 GEV MAJOR PROCUREMENT CATAGORY | 3113B | VENDOR FAB - VAC VESSELS LOT #1, 2 & 3 |
| 12 GEV MAJOR PROCUREMENT CATAGORY | 3113C | VENDOR FAB - BEAM PIPES |
| 12 GEV MAJOR PROCUREMENT CATAGORY | 3113D | VENDOR FAB - TOP HATS LOT #1, 2 & 3 |
| 12 GEV MAJOR PROCUREMENT CATAGORY | 32111 | VENDOR FAB - KLYSTRONS |
| 12 GEV MAJOR PROCUREMENT CATAGORY | 32112A | VENDOR FAB - HVPS LOTS #1, 2, & 3 |
| 12 GEV MAJOR PROCUREMENT CATAGORY | 32113 | VENDOR FAB - WAVEGUIDE COMPONENTS |
| 12 GEV MAJOR PROCUREMENT CATAGORY | 3221 | VENDOR FAB - 1000KW & 600/500KW BOX PS - ARC & SEPTA |
| 12 GEV MAJOR PROCUREMENT CATAGORY | 3223 | VENDOR FAB - 20 A TRIM POWER SUPPLIES |
| 12 GEV MAJOR PROCUREMENT CATAGORY | 3311 | VENDOR PRODUCTION - CHL HELIUM COMPRESSORS |
| 12 GEV MAJOR PROCUREMENT CATAGORY | 33111 | COMMISSION CHL HELIUM PLANT |
| 12 GEV MAJOR PROCUREMENT CATAGORY | 3312 | VENDOR PRODUCTION - CHL 4.5K REFRIGERATOR COL BOX |
| 12 GEV MAJOR PROCUREMENT CATAGORY | 3317 | FAB AND INSTALL CHL INSTRUMENTATION & CONTROLS |
| 12 GEV MAJOR PROCUREMENT CATAGORY | 3411A | VENDOR FAB - SEPTA (S/R DIPOLES) |
| 12 GEV MAJOR PROCUREMENT CATAGORY | 3411B | VENDOR FAB - CURVED DIPOLES (S/R DIPOLES) |
| 12 GEV MAJOR PROCUREMENT CATAGORY | 3421 | VENDOR FAB - H STEEL (EXISTING ARC DIPOLES) |
| 12 GEV MAJOR PROCUREMENT CATAGORY | 3422 | VENDOR FAB - QUADS (EXISTING ARC,ARC 10 & H-D Q-POLES) |
| 12 GEV MAJOR PROCUREMENT CATAGORY | 3451 | VENDOR FAB - 4M DIPOLES (ARC 10 & H-D DIPOLES) |
| 12 GEV MAJOR PROCUREMENT CATAGORY | 3611A | PROCUREMENT - SEE BPM'S |
| 12 GEV MAJOR PROCUREMENT CATAGORY | 4211 | TORUS |
| 12 GEV MAJOR PROCUREMENT CATAGORY | 4212 | SOLENOID |
| 12 GEV MAJOR PROCUREMENT CATAGORY | 42211 | SVT-P DAQ PRODUCTION, SILICON SENSOR ASSY'S |
| 12 GEV MAJOR PROCUREMENT CATAGORY | 4241 | ADC VENDOR FAB |
| 12 GEV MAJOR PROCUREMENT CATAGORY | 4242 | TDC VENDOR FAB |
| 12 GEV MAJOR PROCUREMENT CATAGORY | 4311 | HB MAGNET |
| 12 GEV MAJOR PROCUREMENT CATAGORY | 4312 | Q1 MAGNET |
| 12 GEV MAJOR PROCUREMENT CATAGORY | 4313 | Q2 & Q3 MAGNETS |
| 12 GEV MAJOR PROCUREMENT CATAGORY | 4314 | DIPOLE |
| 12 GEV MAJOR PROCUREMENT CATAGORY | 4315 | JLAB PROCUREMENTS |
| 12 GEV MAJOR PROCUREMENT CATAGORY | 4362A | PRE-FAB MAIN STEEL OF SUPPORT STRUCTURE |
| 12 GEV MAJOR PROCUREMENT CATAGORY | 4362B | FINALIZE DESIGN OF SUPPORT STRUCTURE |
| 12 GEV MAJOR PROCUREMENT CATAGORY | 4362C | PRE-FAB DOUBLE BOGIES & WHEELS OF SUPPORT STRUCTURE |
| 12 GEV MAJOR PROCUREMENT CATAGORY | 5221A | PROCURE SCIFI MODULES |
| 12 GEV MAJOR PROCUREMENT CATAGORY | 5221B | BARREL CALORIMETER FAB |
| 12 GEV MAJOR PROCUREMENT CATAGORY | 5221C | PROCURE SIPMs (BAR CAL) |
| 12 GEV MAJOR PROCUREMENT CATAGORY | 5222 | PROCURE COCKROFT WALTON PARTS (FWD CAL) |
| 12 GEV MAJOR PROCUREMENT CATAGORY | 531 | DAQ HARDWARE |
| 12 GEV MAJOR PROCUREMENT CATAGORY | 541A | VENDOR FAB fADCs FOR DCs (FADC) |
| 12 GEV MAJOR PROCUREMENT CATAGORY | 541B | VENDOR FAB fADCs FOR PMTs (FADC) |
| 12 GEV MAJOR PROCUREMENT CATAGORY | 544A | ADC/TDC CRATES/RACKS |
| 12 GEV MAJOR PROCUREMENT CATAGORY | 544B | PROCURE CRATE DAQ TYPE (CRATES/RACKS) |
| 12 GEV MAJOR PROCUREMENT CATAGORY | 545 | CFDs, HV CRATES, DC CARDS, (LOGIC, HV) |
| 12 GEV MAJOR PROCUREMENT CATAGORY | 5511 | TAGGING MAGNET MEASUREMENTS |
| 12 GEV MAJOR PROCUREMENT CATAGORY | 6111 | N&S ACCESS CONSTRUCTION CONTRACT PROGRESS |
| 12 GEV MAJOR PROCUREMENT CATAGORY | 6112 | N&S ACCESS UTILITIES CONSTRUCTION CONTRACT PROGRESS |
| 12 GEV MAJOR PROCUREMENT CATAGORY | 6114 | TUNNEL A/C CONSTRUCTION CONTRACT PROGRESS |
| 12 GEV MAJOR PROCUREMENT CATAGORY | 621 | CHL ADDITION |
| 12 GEV MAJOR PROCUREMENT CATAGORY | 6222A | ELECTRICAL DISTRIBUTION PROCURE TRANSFORMERS |
| 12 GEV MAJOR PROCUREMENT CATAGORY | 6222B | ELECTRICAL DISTRIBUTION & COOLING WATER CONTRACT PROGRESS |
| 12 GEV MAJOR PROCUREMENT CATAGORY | 6223 | COOLING WATER TOWER PROCURE TOWERS AND PUMPS |
| 12 GEV MAJOR PROCUREMENT CATAGORY | 631A | CONSTRUCTION MANAGEMENT |
| 12 GEV MAJOR PROCUREMENT CATAGORY | 631B | HALL D CONSTRUCTION |
| 12 GeV 1st level Critical Path | 1 | 1st level Critical path |
| 12 GeV 2nd level Critical Path | 2 | 2nd level Critical Path |
| 12 GeV 3rd level Critical Path | 3 | 3rd level Critical path |
| 12 GeV 4th level Critical Path | 4 | 12 GeV CD3 CP |
| 12 GeV 5th level Critical Path | 5 | 12 GeV 5th CP |
| 12GEV INSTALLATION SCOPE | W/A DIPOLES | W/ARC DIPOLES |
| ACT BRIDGING FY SPLIT | FY08-09 | ACT BRIDGING FY08-09 |
| Activities with Steps | NB | Notebook Entry |
| Activities with Steps | ST | Activity with Steps |
| Advance Purchase Plan > 500K | APP | Advance Purchase Plan > 500 K |
| BOE Adder | NO | No Adder |
| BOE Adder | YES | Adder Present |
| BOE Expenses | CP | Catalog Prices |
| BOE Expenses | EJ | Engineering Judgement |
| BOE Expenses | EV | Estimates from vendors/consultants |
| BOE Expenses | PE | JLab Experience |
| BOE Labor | EJ | Engineering Judgement |
| BOE Labor | PE | JLab Experience |
| BOE Procurement | CP | Catalog Prices |
| BOE Procurement | EJ | Engineering Judgement |
| BOE Procurement | EV | Estimates from vendors/consultants |
| BOE Procurement | OB | Obligated |
| BOE Procurement | PE | JLab Experience |
| BOE Procurement | VQ | Quotes from vendors |
| CAM RESPONSIBLE | BILL M | BILL MERZ |
| CAM RESPONSIBLE | CLAUS R | CLAUS RODE |
| CAM RESPONSIBLE | DANA A | DANA ARENIUS |
| CAM RESPONSIBLE | ELKE A | ELKE ASCHENAUR |
| CAM RESPONSIBLE | EUGENE C | EUGENE CHUDAKOV |
| CAM RESPONSIBLE | HOWARD F | HOWARD FENKER |
| CAM RESPONSIBLE | JOHN H | JOHN HOGAN |
| CAM RESPONSIBLE | JOHN L | JOHN LEROSE |
| CAM RESPONSIBLE | LATIFA E | LATIFA ELOUADRHIRI |
| CAM RESPONSIBLE | LEIGH H | LEIGH HARWOOD |
| CAM RESPONSIBLE | MIKE B | MIKE BEVINS |
| CAM RESPONSIBLE | MIKE S | MIKE SPATA |
| CAM RESPONSIBLE | REBECCA Y | REBECCA YASKY |
| CAM RESPONSIBLE | ROLF E | ROLF ENT |
| CAM RESPONSIBLE | YOUNG G | GLENN YOUNG |
| CIVIL CRITICAL MILESTONES | CVL | CIVIL CRITICAL MILESTONES |
| CR 07-002 | 07-002 | CR #07-002 |
| CR 07-003 | 07-003 | CR 07-003 |
| CR 07-005 | 07-005 | CR 07-005 |
| CR 07-009 | 07-009 | CR 07-009 |
| CR 07-010 | 07-010 | CR 07-010 |
| CR 07-012 | 07-012 | CR 07-012 |
| CR 07-014 | 07-014 | CR 07-014 |
| CR 07-015 | 07-015 | CR 07-015 |
| CR 07-016 | 07-016 | CR 07-016 |
| CR 07-017 | 07-017 | CR 07-017 |
| CR 07-018 | 07-018 | Cr 07-018 |
| CR 07-019 | 07-019 | CR 07-019 |
| CR 07-021 | 07-021 | CR 07-021 |
| CR 07-024 | 07-024 | CR 07-024 |
| CR 07-025 | 07-025 | CR 07-025 |
| CR 07-026 | 07-026 | CR 07-026 |
| CR 07-027 | 07-027 | CR 07-027 |
| CR 07-029 | 07-029 | CR 07-029 |
| CR 07-031 | 07-031 | CR 07-031 |
| CR 07-032 | 07-032 | CR 07-032 |
| CR 07-033 | 07-033 | CR 07-033 |
| CR 07-034 | 07-034 | CR 07-034 |
| CR 08-002 | 08-002 | CR 08-002 |
| CR 08-003 | 08-003 | CR 08-003 |
| CR 08-004 | 08-004 | CR 08-004 |
| CR 08-005 | 08-005 | CR 08-005 |
| CR 08-009 | 08-009 | CR 08-009 |
| CR 08-010 | 08-010 | CR 08-010 |
| CR 08-011 | 08-011 | CR 08-011 |
| CR 08-013 | 08-013 | CR 08-013 |
| CR 08-014 | 08-014 | CR 08-014 |
| CR 08-016 | 08-016 | CR 08-016 |
| CR 08-017 | 08-017 | CR 08-017 |
| CR 08-020 | 08-020 | CR 08-020 |
| CR 08-021 | 08-021 | CR 08-021 |
| CR 08-022 | 08-022 | CR 08-022 |
| CR 08-023 | 08-023 | CR 08-023 |
| CR 08-025 | 08-025 | CR 08-025 |
| CR 08-026 | 08-026 | CR 08-026 |
| CR 08-027 | 08-027 | CR 08-027 |
| CR 08-028 | 08-028 | CR 08-028 |
| CR 08-029 | 08-029 | CR 08-029 |
| CR 08-031 | 08-031 | CR 08-031 |
| CR 08-032 | 08-032 | CR 08-032 |
| CR 08-034 | 08-034 | CR 08-034 |
| CR 08-035 | 08-035 | CR 08-035 |
| CR 08-036 | 08-036 | CR 08-036 |
| CR 08-038 | 08-038 | CR 08-038 |
| CR 08-039 | 08-039 | CR 08-039 |
| CR 08-040 | 08-040 | CR 08-040 |
| CR 08-041 | 08-041 | CR 08-041 |
| CR 08-042 | 08-042 | CR 08-042 |
| CR 08-043 | 08-043 | CR 08-043 |
| CR 08-044 | 08-044 | CR 08-044 |
| CR 08-045 | 08-045 | CR 08-045 |
| CR 08-046 | 08-046 | CR 08-046 |
| CR 08-048 | 08-048 | CR 08-048 |
| CR 08-049 | 08-049 | CR 08-049 |
| CR 08-050 | 08-050 | CR 08-050 |
| CR 08-051 | 08-051 | CR 08-051 |
| CR 08-052 | 08-052 | CR 08-052 |
| CR 08-054 | 08-054 | CR 08-054 |
| CR 08-055 | 08-055 | CR 08-055 |
| CR 08-056 | 08-056 | CR 08-056 |
| CR 08-057 | 08-057 | CR 08-057 |
| CR 08-058 | 08-058 | CR 08-058 |
| CR 08-059 | 08-059 | CR 08-059 |
| CR 08-060 | 08-060 | CR 08-060 |
| CR 09-001 | 09-001 | CR 09-001 |
| CR 09-002 | 09-002 | CR 09-002 |
| CR 09-003 | 09-003 | CR 09-003 |
| CR 09-004 | 09-004 | CR 09-004 |
| CR 09-005 | 09-005 | CR 09-005 |
| CR 09-007 | 09-007 | CR 09-007 |
| CR 09-008 | 09-008 | CR 09-008 |
| CR 09-009 | 09-009 | CR 09-009 |
| CR 09-009A | 09-009A | CR-09-009A |
| CR 09-010 | 09-010 | CR 09-010 |
| CR 09-010A | 09-010A | CR09-010A |
| CR 09-011 | 09-011 | CR 09-011 |
| CR 09-012 | 09-012 | CR 09-012 |
| CR 09-014 | 09-014 | CR 09-014 |
| CR 09-015 | 09-015 | CR 09-015 |
| CR 09-016 | 09-016 | CR 09-016 |
| CR 09-017 | 09-017 | CR 09-017 |
| CR 09-022 | 09-022 | CR09-022 |
| CR 09-023 | 09-023 | CR09-023 |
| CR 09-024 | 09-024 | CR09-024 |
| CR 09-026 | 09-026 | CR09-026 |
| CR 09-027 | 09-027 | CR 09-027 |
| CR 09-027 Repair | 09-027 | CR 09-027 |
| CR 09-028 | 09-028 | CR 09-028 |
| CR 09-028 Repair | 09-028 | CR 09-028 |
| CR 09-030 | 09-030 | CR 09-030 |
| CR 09-030 Repair | 09-030 | CR 09-030 |
| CR 09-031 | 09-031 | CR 09-031 |
| CR 09-031 Repair | 09-031 | CR 09-031 |
| CR 09-032 | 09-032 | CR 09-032 |
| CR 09-032 Repair | 09-032 | CR 09-032 |
| CR 09-033 | 09-033 | CR 09-033 |
| CR 09-033 Repair | 09-033 | CR 09-033 |
| CR 09-034 | 09-034 | CR 09-034 |
| CR 09-035 | 09-035 | CR 09-035 |
| CR 09-036 | 09-036 | CR 09-036 |
| CR 09-037 | 09-037 | CR 09-037 |
| CR 09-038 | 09-038 | CR 09-038 |
| CR 09-039 | 09-039 | CR 09-039 |
| CR 09-040 | 09-040 | CR 09-040 |
| CR 09-041 | 09-041 | CR 09-041 |
| CR 09-042 | 09-042 | CR 09-042 |
| CR 09-043 | 09-043 | CR 09-043 |
| CR 09-044 | 09-044 | CR 09-044 |
| CR 09-045 | 09-045 | CR 09-045 |
| CR 09-046 | 09-046 | CR 09-046 |
| CR 09-047 | 09-047 | CR 09-047 |
| CR 09-048 | 09-048 | CR 09-048 |
| CR 09-049 | 09-049 | CR 09-049 |
| CR 09-051 | 09-051 | CR 09-051 |
| CR 09-052 | 09-052 | CR09-052 |
| CR 09-053 | 09-053 | CR 09-053 |
| CR 10-001 | 10-001A | CR 10-001A |
| CR 10-001 | 10-001B | CR 10-001B |
| CR 10-001 | 10-1VA | CR VA10-001 |
| CR 10-002 | 10-002 | CR 10-002 |
| CR 10-003 | 10-003 | CR 10-003 |
| CR 10-004 | 10-004 | CR 10-004 |
| CR 10-005 | 10-005 | CR 10-005 |
| CR 10-007 | 10-007 | CR 10-007 |
| CR 10-008 | 10-008 | CR 10-008 |
| CR 10-009 | 10-009 | CR 10-009 |
| CR 10-010 | 10-010 | CR 10-010 |
| CR 10-011 | 10-011 | CR 10-011 |
| CR 10-012 | 10-012 | CR 10-012 |
| CR 10-012A | 10-012A | CR 10-012A |
| CR 10-014 | 10-014 | CR 10-014 |
| CR 10-015 | 10-015 | CR 10-015 |
| CR 10-016 | 10-016 | CR 10-016 |
| CR 10-017 | 10-017 | CR 10-017 |
| CR 10-018 | 10-018 | CR 10-018 |
| CR 10-019 | 10-019 | CR 10-019 |
| CR 10-020 | 10-020 | CR 10-020 |
| CR 10-021 | 10-021 | CR 10-021 |
| CR 10-022 | 10-022 | CR 10-022 |
| CR 10-023 | 10-023 | CR 10-023 |
| CR 10-024 | 10-024 | CR 10-024 |
| CR 10-025 | 10-025 | CR 10-025 |
| CR 10-026 | 10-026 | CR 10-026 |
| CR 10-027 | 10-027 | CR 10-027 |
| CR 10-028 | 10-028 | CR 10-028 |
| CR 10-029 | 10-029 | CR 10-029 |
| CR 10-030 | 10-030 | CR 10-030 |
| CR 10-031 | 10-031 | CR 10-031 |
| CR 10-032 | 10-032 | CR 10-032 |
| CR 10-033 | 10-033 | CR 10-033 |
| CR 10-034 | 10-034 | CR 10-034 |
| CR 10-035 | 10-035 | CR 10-035 |
| CR 10-036 | 10-036 | CR 10-036 |
| CR 10-037 | 10-037 | CR 10-037 |
| CR 10-038 | 10-038 | CR 10-038 |
| CR 10-039 | 10-039 | CR 10-039 |
| CR 10-040 | 10-040 | CR 10-040 |
| CR 10-041 | 10-041 | CR 10-041 |
| CR 10-042 | 10-042 | CR 10-042 |
| CR 10-043 | 10-043 | CR 10-043 |
| CR 10-044 | 10-044 | CR 10-044 |
| CR 10-045 | 10-045 | CR 10-045 |
| CR 10-046 | 10-046 | CR 10-046 |
| CR 10-048 | 10-048 | CR 10-048 |
| CR 10-050 | 10-050 | CR 10-050 |
| CR 10-051 | 10-051 | CR 10-051 |
| CR 10-052 | 10-052 | CR 10-052 |
| CR 10-053 | 10-053 | CR 10-053 |
| CR 10-054 | 10-054 | CR 10-054 |
| CR 10-055 | 10-055 | CR 10-055 |
| CR 10-056 | 10-056 | CR 10-056 |
| CR 10-057 | 10-057 | CR 10-057 |
| CR 10-058 | 10-058 | CR 10-058 |
| CR 10-059 | 10-059 | CR 10-059 |
| CR 10-060 | 10-060 | CR 10-060 |
| CR 10-061 | 10-061 | CR 10-061 |
| CR 10-063 | 10-063 | CR 10-063 |
| CR 10-064 | 10-064 | CR 10-064 |
| CR 10-065 | 10-065 | CR 10-065 |
| CR 10-066 | 10-066 | CR 10-066 |
| CR 10-067 | 10-067 | CR 10-067 |
| CR 10-069 | 10-069 | CR 10-069 |
| CR 10-070 | 10-070 | CR 10-070 |
| CR 10-071 | 10-071 | CR 10-071 |
| CR 10-074 | 10-074 | CR 10-074 |
| CR 10-075 | 10-075 | CR 10-075 |
| CR 10-076 | 10-076 | CR 10-076 |
| CR 10-077 | 10-077 | CR 10-077 |
| CR 11-001 | 11-001 | CR 11-001 |
| CR 11-001 | 11-1VA | CR VA11-001 |
| CR 11-002 | 11-002 | CR 11-002 |
| CR 11-003 | 11-003 | CR 11-003 |
| CR 11-004 | 11-004 | CR 11-004 |
| CR 11-005 | 11-005 | CR 11-005 |
| CR 11-006 | 11-006 | CR 11-006 |
| CR 11-007 | 11-007 | CR 11-007 |
| CR 11-008 | 11-008 | CR 11-008 |
| CR 11-009 | 11-009 | CR 11-009 |
| CR 11-010 | 11-010 | CR 11-010 |
| CR 11-011 | 11-011 | CR 11-011 |
| CR 11-012 | 11-012 | CR 11-012 |
| CR 11-013 | 11-013 | CR 11-013 |
| CR 11-014 | 11-014 | CR 11-014 |
| CR 11-015 | 11-015 | CR 11-015 |
| CR 11-016 | 11-016 | CR 11-016 |
| CR 11-017 | 11-017 | CR 11-017 |
| CR 11-018 | 11-018 | CR 11-018 |
| CR 11-019 | 11-019 | CR 11-019 |
| CR 11-020 | 11-020 | CR 11-020 |
| CR 11-021 | 11-021 | CR 11-021 |
| CR 11-022 | 11-022 | CR 11-022 |
| CR 11-022a | 11-022a | CR 11-022a |
| CR 11-023 | 11-023 | CR 11-023 |
| CR 11-024 | 11-024 | CR 11-024 |
| CR 11-025 | 11-025 | CR 11-025 |
| CR 11-026 | 11-026 | CR 11-026 |
| CR 11-027 | 11-027 | CR 11-027 |
| CR 11-028 | 11-028 | CR 11-028 |
| CR 11-029 | 11-029 | CR 11-029 |
| CR 11-030 | 11-030 | CR 11-030 |
| CR 11-031 | 11-031 | CR 11-031 |
| CR 11-032 | 11-032 | CR 11-032 |
| CR 11-035 | 11 -035 | CR 11-035 |
| CR 11-036 | 11-036 | CR 11-036 |
| CR 11-037 | 11-037 | CR 11-037 |
| CR 11-038 | 11-038 | CR 11-038 |
| CR 11-039 | 11-039 | CR 11-039 |
| CR 11-040 | 11-040 | CR 11-040 |
| CR 11-041 | 11-041 | CR 11-041 |
| CR 11-042 | 11-042 | CR 11-042 |
| CR 11-043 | 11-043 | CR 11-043 |
| CR 11-044 | 11-044 | CR 11-044 |
| CR 11-045 | 11-045 | CR 11-045 |
| CR 11-046 | 11-046 | CR 11-046 |
| CR 11-047 | 11-047 | CR 11-047 |
| CR 11-048 | 11-048 | CR 11-048 |
| CR 11-049 | 11-049 | CR 11-049 |
| CR 11-051 | 11-051 | CR 11-051 |
| CR 11-052 | 11-052 | CR 11-052 |
| CR 11-053 | 11-053 | CR 11-053 |
| CR 11-054 | 11-054 | CR 11-054 |
| CR 11-055 | 11-055 | CR 11-055 |
| CR 11-056 | 11-056 | CR11-056 |
| CR 11-057 | 11-057 | CR 11-057 |
| CR 11-058 | 11-058 | CR 11-058 |
| CR 11-059 | 11-059 | CR 11-059 |
| CR 11-VA2 | 11-VA2 | CR 11-VA2 |
| CR 11-VA3 | 11-VA3 | CR 11-VA3 |
| CR 12-001 | 12-001 | CR 12-001 |
| CR 12-002 | 12-002 | CR 12-002 |
| CR 12-003 | 12-003 | CR 12-003 |
| CR 12-005 | 12-005 | CR 12-005 |
| CR 12-007 | 12-007 | CR 12-007 |
| CR 12-008 | 12-008 | CR 12-008 |
| CR 12-009 | 12-009 | CR 12-009 |
| CR 12-011 | 12-011 | CR 12-011 |
| CR 12-012 | 12-012 | CR 12-012 |
| CR 12-013 | 12-013 | CR 12-013 |
| CR 12-014 | 12-014 | CR 12-014 |
| CR 12-015 | 12-015 | CR 12-015 |
| CR 12-016 | 12-016 | CR 12-016 |
| CR 12-017 | 12-017 | CR 12-017 |
| CR 12-018 | 12-018 | CR 12-018 |
| CR 12-018 | 12-018F | CR 12-018F Float Changes Only |
| CR 12-021 | 12-021 | CR 12-021 |
| CR 12-021 | 12-021F | CR12-021 Float Only |
| CR 12-022 | 12-022 | CR 12-022 |
| CR 12-022 | 12-022F | CR 12-022F Float Only |
| CR 12-023 | 12-023 | CR 12-023 |
| CR 12-024 | 12-024 | CR 12-024 |
| CR 12-024 | 12-024F | CR 12-024 Float Only |
| CR 12-025 | 12-025 | CR 12-025 |
| CR 12-026 | 12-026 | CR 12-026 |
| CR 12-026 | 12-026F | CR12-026 Float Only |
| CR 12-027 | 12-027 | CR 12-027 |
| CR 12-027 | 12-027F | CR12-027F Float Only |
| CR 12-028 | 12-028 | CR 12-028 |
| CR 12-028 | 12-028F | CR 12-028F Float Only |
| CR 12-029 | 12-029 | CR 12-029 |
| CR 12-029 | 12-029F | CR 12-029F Float Only |
| CR 12-029A | 12-029A | CR 12-029A |
| CR 12-032 | 12-032 | CR 12-032 |
| CR 12-032 | 12-032F | CR 12-032 Float Only |
| CR 12-034 | 12-034 | CR 12-034 |
| CR 12-034 | 12-034F | CR 12-034 Float Only |
| CR 12-035 | 12-035 | CR 12-035 |
| CR 12-035 | 12-035F | CR 12-035 Float Only |
| CR 12-036 | 12-036 | CR 12-036 |
| CR 12-036 | 12-036F | CR 12-036 Float Only |
| CR 12-037 | 12-037 | CR 12-037 |
| CR 12-037 | 12-037F | CR 12-037 Float Only |
| CR 12-038 | 12-038 | CR 12-038 |
| CR 12-039 | 12-039 | CR 12-039 |
| CR 12-039 | 12-039F | CR 12-039 Float Only |
| CR 12-040 | 12-040 | CR 12-040 |
| CR 12-042 | 12-042 | CR 12-042 |
| CR 12-043 | 12-043 | CR 12-043 |
| CR 12-044 | 12-044 | CR 12-044 |
| CR 12-044 | 12-044F | CR 12-044 Float Only |
| CR 12-045 | 12-045 | CR 12-045 |
| CR 12-046 | 12-046 | CR 12-046 |
| CR 12-047 | 12-047 | CR 12-047 |
| CR 12-047 | 12-047F | CR 12-047 Float only |
| CR 12-049 | 12-049 | CR 12-049 |
| CR 12-050 | 12-050 | CR 12-050 |
| CR 12-050 | 12-050F | CR 12-050 Float only |
| CR 12-051 | 12-051 | CR 12-051 |
| CR 12-051 | 12-051F | CR 12-051 Float Only |
| CR 12-052 | 12-052 | CR 12-052 |
| CR 12-053 | 12-053 | CR 12-053 |
| CR 12-053 | 12-053F | CR 12-053 Float Only |
| CR 12-054 | 12-054 | CR 12-054 |
| CR 12-054 | 12-054F | CR 12-054 Float Only |
| CR 12-055 | 12-055 | CR 12-055 |
| CR 13-002 | 13-002 | CR 13-002 |
| CR 13-002 | 13-002F | CR 13-002 Float Only |
| CR 13-003 | 13-003 | CR 13-003 |
| CR 13-003 | 13-003F | CR 13-003 Float Only |
| CR 13-004 | 13-004 | CR 13-004 |
| CR 13-005 | 13-005 | CR 13-005 |
| CR 13-005 | 13-005F | CR 13-005 Float Only |
| CR 13-006 | 13-006 | CR 13-006 |
| CR 13-006 | 13-006F | CR 13-006 Float Only |
| CR 13-007 | 13-007 | CR 13-007 |
| CR 13-007 | 13-007F | CR 13-007 Float Only |
| CR 13-008 | 13-008 | CR 13-008 |
| CR 13-009 | 13-009 | CR 13-009 |
| CR 13-009 | 13-009F | CR 13-009 Float Only |
| CR 13-010 | 13-010 | CR 13-010 |
| CR 13-011 | 13-011 | CR 13-011 |
| CR 13-015 | 13-015 | CR 13-015 |
| CR 13-016 | 13-016 | CR 13-016 |
| CR 14-001 | 14-001 | CR 14-001 |
| DOWN PERIOD | 6MON | 6 MONTH (2011) |
| Duplications | DUP | Activity Duplication Between Projects |
| EVMS Reporting Codes | C | % Effort (Civil Construction) |
| EVMS Reporting Codes | D | % Delivered (Delivery of Contracted Items %) |
| EVMS Reporting Codes | E | LOE (equation) |
| EVMS Reporting Codes | H | 0/50/100% (</=$50K or </= 2Months) |
| EVMS Reporting Codes | M | 0-100% Milestone (No EV) |
| EVMS Reporting Codes | N/A | Not Applicable (FY08 or in progress) |
| EVMS Reporting Codes | P | 0-100% (Pre-Contract Peg Points, 0% until Contract CR is implemented |
| EVMS Reporting Codes | S | Special (CAM written and PM approved plan for act bar phases) |
| EVMS Reporting Codes | U | % Units Complete (In-house Fab, recving, install, test, or checkout of Mult units) |
| EVMS Reporting Codes | Z | Zero Budget |
| EXPNS ACT BRIDGING FY SPLIT | EXP0809 | EXP ACT BRIDGING FY08-09 |
| FNSH%COMP for CM EVM | 1 | % Complete |
| GROP Group | ACCL | Accelerator |
| GROP Group | CDS | Critical Decision Schedule |
| GROP Group | CVL | Civil |
| HALL D Related Milestones | D | Related to Hall D |
| In Progress Procurements | Split | To Be Split |
| Installation | Install | Installation |
| Inter Project Link (IPL) | IPL | Inter Project Link |
| MARCH!!! | XX | REVIEW |
| MILE - Milestone | 0 | 1.0 CD SCHEDULE |
| MILE - Milestone | 2 | 1.6 CIVIL |
| MILE - Milestone | 4 | 1.3 ACCELERATOR |
| Milestone Level | 1 | Level 1 |
| Milestone Level | 2 | Level 2 |
| Milestone Level | 3 | Level 3 |
| Milestone Level | 4 | Level 4 |
| Milestone Level | 5 | Level 5 |
| Milestone Level | 6 | Level 6 |
| Milestone Level | 9 | Level 9 |
| New H Claim | Aug 12 | August 12 Start |
| OPC Allison | OPC A | Allison's OPC 7/27/12 |
| Obligated Prior to Rebaseline | OB | Obligated Prior to Rebaseline |
| Obligated Prior to Rebaseline | OB-2 | Obligated Post Rebaseline |
| PHAS - Project Phase | IN | Installation |
| Pat's Code | Pat | Pat Temp Code |
| Phil Dev | MP | Major Procurement |
| Phil Dev | Phil | Dev |
| Post Rebaseline | PR | Post Rebaselined Schedule |
| Previously In Progress | Review | Review Resources |
| Profile change | C | CR Change |
| Proj SYS CODE | BM TR 12GE | 12 GEV BEAM TRANSPORT |
| RESP - Responsibility | ARENIUS D | Arenius, Dana |
| RESP - Responsibility | BEVINS M | Bevins, Michael |
| RESP - Responsibility | BICKLEY M | Bickley, Matt |
| RESP - Responsibility | BROOKS W | Brooks, Will |
| RESP - Responsibility | CHANDRA S | Chandra, Suresh |
| RESP - Responsibility | CHUDAKOV | Chudakov, Eugene |
| RESP - Responsibility | DOE | Department of Energy |
| RESP - Responsibility | ELOUADRHIRI L | Elouadrhiri, Latifa |
| RESP - Responsibility | FENKER H | Fenker, Howard |
| RESP - Responsibility | GARZA O | Garza, Omar |
| RESP - Responsibility | HARWOOD L | Harwood, Leigh |
| RESP - Responsibility | HOGAN J | Hogan, John |
| RESP - Responsibility | HOVATER C | Hovater, Curt |
| RESP - Responsibility | LEROSE J | LeRose, John |
| RESP - Responsibility | MAHONEY K | Mahoney, Kelly |
| RESP - Responsibility | MERZ B | Merz, Bill |
| RESP - Responsibility | NELSON R | Nelson, Rick |
| RESP - Responsibility | PARKINSON J | Parkinson, Jim |
| RESP - Responsibility | RODE C | Rode, Claus |
| RESP - Responsibility | SPATA M | Spata, Mike |
| RESP - Responsibility | WHITLATCH C | Whitlatch, Celia |
| RESP - Responsibility | WINES R | Wines, Robin |
| RESP - Responsibility | YASKY R | Yasky, Rebecca |
| RESP - Responsibility | YOUNG G | GLENN YOUNG |
| ReBaseline Actuals Adjustment | ADJ | Actuals Adjustment |
| Risk Item Number | 2,3,4 | Combination |
| STRT%COMP for CM EVM | 1 | % Complete |
| SVT | HBI | (New Code Value) |
| SVT | MECH | (New Code Value) |
| Schedule Contingency | SC | Schedule Contingency Added |
| Special | LR | m1 |
| Temple/Lehman | LR13 | Lehman 13 Change from Temple |
